# RIYADH METRO PROJECT STATION 1F5_BASELINE SCHEDULE a

Schedule from Primavera P6, 2018-08-29 to 2020-09-22, data date 2018-08-29, costs in SAR.
Must finish by 2020-09-23

## Calendars

- 1F5: Mon-Thu 07:00-17:00; Fri off; Sat-Sun 07:00-17:00. Exceptions (off unless hours are given): 2019-06-04 to 2019-06-06, 2019-08-10 to 2019-08-12, 2019-09-23, 2019-09-25 08:00-16:00, 2020-05-24 to 2020-05-26, 2020-08-01 to 2020-08-03.
- Saudi: Mon-Thu 07:00-17:00; Fri off; Sat-Sun 07:00-17:00.

## Resources

| Resource | Group | Unit | Rate | Notes |
| --- | --- | --- | --- | --- |
| Unskilled Labour | labor |  | 0.08 |  |
| Skilled Labour | labor |  | 0.08 |  |
| Fire Fighting Crew | labor |  | 0.09 |  |
| Electrical Crew | labor |  | 0.09 |  |
| Plumbing Crew | labor |  | 0.09 |  |
| Mechanical Crew | labor |  | 0.09 |  |
| Helper | labor |  | 0.07 |  |
| Mason | labor |  | 0.07 |  |
| Concrete Casting | material | CUM |  |  |
| Carpenter | labor |  | 0.07 |  |
| Steel Fixer | labor |  | 0.07 |  |
| Steel Reinforcement | material | tons |  |  |
| Concrete infill | material | CUM |  |  |
| Formworks | material | Square Meter |  |  |
| Painting | material | Square Meter |  |  |
| Block Work | material | Square Meter |  |  |
| Plaster Work | material | Square Meter |  |  |
| Screed Work | material | Square Meter |  |  |
| FIRE FIGHTING | labor |  | 0.09 |  |
| 1F5-MOB | labor |  | 0.46 | ï»¿ |
| 1F5-Management | labor |  |  |  |
| HVAC | labor |  | 0.09 |  |
| Duct Installation | material | Sqmt |  |  |
| Duct Insulation | material | Sqmt |  |  |
| FF pipe | material | Limt |  |  |
| 1F5-Riggers | labor |  | 0.07 |  |
| 1F5-Scaffolders | labor |  | 0.07 |  |

## Schedule

| ID | WBS | Activity | Type | Duration | Start | Finish | Predecessors | Total float | Free float | Constraint | Discipline | AREA |
| --- | --- | --- | --- | --- | --- | --- | --- | --- | --- | --- | --- | --- |
|  | 1 | **MILESTONE** |  |  | 2018-08-29 | 2020-09-12 |  |  |  |  |  |  |
|  | 1 | **CONTRACTUAL MILESTONES** |  |  | 2018-10-02 | 2020-09-08 |  |  |  |  |  |  |
| CM010 |  | Complete Mobilization | milestone | 0d | 2018-10-02 | 2018-10-02 | MOB1F5010 | 2.5d | 13.75d | finish on or before 2018-10-04 | Civil |  |
|  | 1 | **SOUTH MAIN BOX** |  |  | 2018-12-08 | 2019-05-22 |  |  |  |  |  |  |
| CM020 |  | RC from completed construction up to Technical Floor (B04) | milestone | 0d | 2018-12-08 | 2018-12-08 | C1C1111F5S820, C1C1111F5S920 | 0d | 8.75d | finish on or before 2018-12-08 | Civil |  |
| CM040 |  | Wet finishes Siemens Room - South . P06 | milestone | 0d | 2019-01-23 | 2019-01-23 | 1F5-FNS-P06-030, 1F5-FNS-P06-050, 1F5-FNS-P06-250 | 8.75d | 27.5d | finish on or before 2019-02-01 | Arch'l |  |
| CM030 |  | RC Roof slab (B01) | milestone | 0d | 2019-04-09 | 2019-04-09 | C1C1111F5S1520 FS+7.5d, C1C1111F5S1610 FS+7.5d | 6.25d | 10d | finish on or before 2019-04-15 | Civil |  |
| CM050 |  | Complete handover to transit system (Siemens) Platform (P06 . AREA-4 & 5) | milestone | 0d | 2019-05-22 | 2019-05-22 | 1F5-FNS-P06-300, 1F5-FNS-P06-090, 1F5-FNS-P06-305, A28362, A28242, A28472, A28402 | 1d | 47.5d | finish on or before 2019-05-23 | Arch'l | 4 |
|  | 2 | **CENTRAL MAIN BOX** |  |  | 2019-01-16 | 2019-07-09 |  |  |  |  |  |  |
| CM070 |  | RC from completed construction up to Technical Floor (B04) | milestone | 0d | 2019-01-16 | 2019-01-16 | C1C1111F5C1150 | 1.25d | 13.75d | finish on or before 2019-01-17 | Civil |  |
| CM080 |  | RC Roof slab (B01) | milestone | 0d | 2019-05-15 | 2019-05-15 | C1C1111F5C1910 FS+7.5d | 6.25d | 10d | finish on or before 2019-05-21 | Civil |  |
| CM090 |  | Complete handover to transit system (Siemens) Platform (P06 . AREA-3) | milestone | 0d | 2019-07-09 | 2019-07-09 | 1F5-FNS-P06-530 FS+15d, A32682 FS+15d, A32562 FS+15d, A33012 FS+15d | 5.5d | 34.25d | finish on or before 2019-07-15 | Arch'l |  |
|  | 3 | **NORTH MAIN BOX** |  |  | 2018-12-02 | 2019-07-09 |  |  |  |  |  |  |
| CM100 |  | RC Base Raft North (B07) | milestone | 0d | 2018-12-02 | 2018-12-02 | C1C1111F5N510, C1C1111F5N470 | -15d | 451.5d | finish on or before 2018-11-18 | Civil |  |
| CM110 |  | Track Access Line 1 (After casting Base Slab & Inner Wall) | milestone | 0d | 2018-12-09 | 2018-12-09 | C1C1111F5N990 | -10d | 444d | finish on or before 2018-11-30 | Civil |  |
| CM120 |  | RC Technical Floor (B04) | milestone | 0d | 2019-03-03 | 2019-03-03 | C1C1111F5N1520, C1C1111F5N1620 | -2.5d | 354d | finish on or before 2019-02-28 | Civil |  |
| CM130 |  | RC Base raft (B07) to Roof Slab (B01) | milestone | 0d | 2019-06-17 | 2019-06-17 | C1C1111F5N2030, C1C1111F5N2000 | 3.75d | 244d | finish on or before 2019-06-21 | Civil |  |
| CM140 |  | Complete handover to Transit System (Siemens) Platform (P06 . AREA-1 & 2) | milestone | 0d | 2019-07-09 | 2019-07-09 | 1F5-FNS-P06-990 FS+15d, 1F5-FNS-P06-750 FS+15d, A36882 FS+15d, A39042 FS+15d | 11.75d | 220.75d | finish on or before 2019-07-21 | Arch'l | 1 |
|  | 4 | **ACY & ENTRANCES** |  |  | 2019-01-31 | 2019-05-11 |  |  |  |  |  |  |
| CM150 |  | RC NE entrance Roof slab (B01) | milestone | 0d | 2019-01-31 | 2019-01-31 | C1C1111F5NEE-260 | -18.75d | 386.5d | finish on or before 2019-01-15 | Civil |  |
| CM160 |  | RC NW entrance Roof slab (B01) | milestone | 0d | 2019-04-01 | 2019-04-01 | C1C1111F5NWE-260 | 3.75d | 322.75d | finish on or before 2019-04-05 | Civil |  |
| CM170 |  | RC ACY | milestone | 0d | 2019-05-11 | 2019-05-11 | C1C1111F5AY1-200, C1C1111F5AY1-240, C1C1111F5AY2-200 | 6.25d | 280.25d | finish on or before 2019-05-18 | Civil |  |
|  | 5 | **ACCESS** |  |  | 2019-02-06 | 2019-08-04 |  |  |  |  |  |  |
| CM230 |  | Access available to Fire Clean Agent | milestone | 0d | 2019-02-06 | 2019-02-06 | A28342 | 2.5d | 306.5d | finish on or before 2019-02-10 | MEP |  |
| CM210 |  | Access available to Fire Alarm System | milestone | 0d | 2019-02-11 | 2019-02-11 | A28262 FS+7.5d | 4.25d | 302d | finish on or before 2019-02-15 | MEP |  |
| CM200 |  | Access available to Building management System | milestone | 0d | 2019-03-11 | 2019-03-11 | A26112 FS+15d | 4.25d | 272d | finish on or before 2019-03-15 | MEP |  |
| CM190 |  | MEP Access available to Elevator / Lift | milestone | 0d | 2019-07-28 | 2019-07-28 | 1F5-FNS-B02-560 FS+6.25d | 2.5d | 126.5d | finish on or before 2019-07-31 | Civil |  |
| CM220 |  | Access available to Tunnel Ventilation System (TVS) | milestone | 0d | 2019-08-04 | 2019-08-04 | A62982 | 8.25d | 119.75d | finish on or before 2019-08-15 | MEP |  |

| ID | WBS | Activity | Type | Duration | Start | Finish | Predecessors | Total float | Free float | Constraint | Discipline | AREA | LOCATION |
| --- | --- | --- | --- | --- | --- | --- | --- | --- | --- | --- | --- | --- | --- |
|  | 6 | **ARCHL & MEP** |  |  | 2019-09-28 | 2020-01-16 |  |  |  |  |  |  |  |
| CM360 |  | MDB/EMDB installation and local testing-South and North (02 Rooms). | milestone | 0d | 2019-09-28 | 2019-09-28 | A56702, A54542, A63192 FF | 1.5d | 155.75d | finish on or before 2019-09-30 | MEP |  |  |
| CM370 |  | MEP works for station | milestone | 0d | 2019-12-29 | 2019-12-29 | A71562 FS+7.5d, A82242 FS+7.5d, A71602 FS+7.5d, A71672, A71442, A71892 FS+7.5d, A73762, A73722 | 10.75d | 57.5d | finish on or before 2020-01-08 | MEP |  |  |
| CM350 |  | Finishing works for Station | milestone | 0d | 2020-01-16 | 2020-01-16 | 1F5-FNS-ACY2-260 FS+7.5d, C1C1111F5N2140, 1F5-FNS-B04-1090, 1F5-FNS-B03-650, 1F5-FNS-P06-900, 1F5-FNS-NWE-260, C1C1111F5N2110, 1F5-FNS-P06-660, C1C1111F5NWE-330, 1F5-FNS-B02-660, 1F5-FNS-P06-1120, 1F5-FNS-B05-3580, 1F5-FNS-NEE-260, C1C1111F5N3050 | 3.75d | 20.5d | finish on or before 2020-01-21 | Arch'l |  |  |
|  | 7 | **COMPLETION** |  |  | 2020-03-22 | 2020-03-23 |  |  |  |  |  |  |  |
| CM380 |  | Complete MEP systems testing & commissioning | milestone | 0d | 2020-03-22 | 2020-03-22 | RMLC2C100987 FS+7.5d | 0.75d | 1.25d | finish on or before 2020-03-23 | MEP |  |  |
| CM390 |  | Complete Station | milestone | 0d | 2020-03-23 | 2020-03-23 | CLO020, CLO030, CLO010 | -0.5d | 113.25d | finish on or before 2020-03-23 | Arch'l |  |  |
|  | 8 | **3RD ENTRANCE** |  |  | 2020-03-09 | 2020-09-08 |  |  |  |  |  |  |  |
| CM400 |  | Start Construction Works for the 3rd Entrance | milestone | 0d | 2020-03-09 | 2020-03-09 | C1C1111F53WE-590 | 7.5d |  | start on or after 2020-03-04 | Civil |  |  |
| CM410 |  | Complete Construction Works for the 3rd Entrance | milestone | 0d | 2020-06-24 | 2020-06-24 | C1C1111F53WE-490 | 0d | 77.5d | finish on or before 2020-06-25 | Civil |  |  |
| CM420 |  | Installation & commissioning works for 3rd Entrance | milestone | 0d | 2020-09-08 | 2020-09-08 | 1F5-FNS-3WE-260 FS+7.5d, CLO020 FF | 0d |  | finish on or before 2020-09-23 | Arch'l |  |  |
|  | 3 | **WORK AREA TURN-OVER BY ARCH'L & MEP TEAMS** |  |  | 2019-01-23 | 2019-11-21 |  |  |  |  |  |  |  |
|  | 1 | **FROM WET FINISHES TEAM TO MEP TEAM** |  |  | 2019-01-23 | 2019-08-14 |  |  |  |  |  |  |  |
|  | 1 | **Base Raft (B07)** |  |  | 2019-03-07 | 2019-05-28 |  |  |  |  |  |  |  |
| RM02 |  | B07 . AREA-5 from Arch'l to MEP | milestone | 0d | 2019-03-07 | 2019-03-07 | 1F5-FNS-P06-140, 1F5-FNS-P06-110, 1F5-FNS-P06-150 | 172.25d | 0d |  | Arch'l | 5 | MB |
| RM01 |  | B07 . AREA-4 from Arch'l to MEP | milestone | 0d | 2019-04-21 | 2019-04-21 | 1F5-FNS-P06-360, 1F5-FNS-P06-330, 1F5-FNS-P06-370 | 117.25d | 0d |  | Arch'l | 4 | MB |
| RM04 |  | B07 . AREA-2 from Arch'l to MEP | milestone | 0d | 2019-04-28 | 2019-04-28 | 1F5-FNS-P06-800, 1F5-FNS-P06-770 | 117.25d | 0d |  | Arch'l | 2 | MB |
| RM05 |  | B07 . AREA-1 from Arch'l to MEP | milestone | 0d | 2019-04-30 | 2019-04-30 | 1F5-FNS-P06-1040, 1F5-FNS-P06-1010 | 122.25d | 0d |  | Arch'l | 1 | MB |
| RM03 |  | B07 . AREA-3 from Arch'l to MEP | milestone | 0d | 2019-05-28 | 2019-05-28 | 1F5-FNS-P06-580 | 77.25d | 0d |  | Arch'l | 3 | MB |
|  | 2 | **Platform Level (P06 )** |  |  | 2019-01-23 | 2019-06-08 |  |  |  |  |  |  |  |
| RM25 |  | P06 . AREA-5 Siemens Rm - from Arch'l to MEP | milestone | 0d | 2019-01-23 | 2019-01-23 | 1F5-FNS-P06-050, 1F5-FNS-P06-030 | 1d | 0d | finish on or before 2019-02-01 | Arch'l | 5 | MB |
| RM15 |  | P06 . AREA-4 Siemens Rm - from Arch'l to MEP | milestone | 0d | 2019-01-26 | 2019-01-26 | 1F5-FNS-P06-250, 1F5-FNS-P06-270 | 4.25d | 0d | finish on or before 2019-02-01 | Arch'l | 4 | MB |
| RM43 |  | P06 . AREA-2 Siemens Rm - from Arch'l to MEP | milestone | 0d | 2019-02-07 | 2019-02-07 | 1F5-FNS-P06-710, 1F5-FNS-P06-690 | 23.5d | 0d | finish on or before 2019-03-08 | Arch'l | 2 | MB |
| RM35 |  | P06 . AREA-3 Siemens Rm - from Arch'l to MEP | milestone | 0d | 2019-02-09 | 2019-02-09 | 1F5-FNS-P06-490 | 5.5d | 0d | finish on or before 2019-03-01 | Arch'l | 3 | MB |
| RM48 |  | P06 . AREA-1 Siemens Rm - from Arch'l to MEP | milestone | 0d | 2019-02-11 | 2019-02-11 | 1F5-FNS-P06-950, 1F5-FNS-P06-930 | 11.75d | 0d | finish on or before 2019-03-08 | Arch'l | 1 | MB |
| RM20 |  | P06 . AREA-5 from Arch'l to MEP | milestone | 0d | 2019-03-07 | 2019-03-07 | 1F5-FNS-P06-140, 1F5-FNS-P06-150 | 157.25d | 0d |  | Arch'l | 5 | MB |
| RM10 |  | P06 . AREA-4 from Arch'l to MEP | milestone | 0d | 2019-04-21 | 2019-04-21 | 1F5-FNS-P06-370 | 109.75d | 47.5d |  | Arch'l | 4 | MB |
| RM40 |  | P06 . AREA-2 from Arch'l to MEP | milestone | 0d | 2019-05-05 | 2019-05-05 | 1F5-FNS-P06-790, 1F5-FNS-P06-810 | 102.25d | 2.5d |  | Arch'l | 2 | MB |
| RM45 |  | P06 . AREA-1 from Arch'l to MEP | milestone | 0d | 2019-05-07 | 2019-05-07 | 1F5-FNS-P06-1030, 1F5-FNS-P06-1050 | 99.75d | 0d |  | Arch'l | 1 | MB |
| RM30 |  | P06 . AREA-3 from Arch'l to MEP | milestone | 0d | 2019-06-08 | 2019-06-08 | 1F5-FNS-P06-590, RM10 | 62.25d | 0d |  | Arch'l | 3 | MB |

| ID | WBS | Activity | Type | Duration | Start | Finish | Predecessors | Total float | Free float | Discipline | AREA | LOCATION |
| --- | --- | --- | --- | --- | --- | --- | --- | --- | --- | --- | --- | --- |
|  | 3 | **Mezzanine Level (B05)** |  |  | 2019-03-03 | 2019-07-17 |  |  |  |  |  |  |
| RM60 |  | B05 . AREA-5 from Arch'l to MEP | milestone | 0d | 2019-03-03 | 2019-03-03 | 1F5-FNS-B05-910 | 139.75d | 0d | Arch'l | 5 | MB |
| RM50 |  | B05 . AREA-4 from Arch'l to MEP | milestone | 0d | 2019-03-23 | 2019-03-23 | 1F5-FNS-B05-1030, 1F5-FNS-B05-1050 | 126d | 0d | Arch'l | 4 | MB |
| RM70 |  | B05 . AREA-3 from Arch'l to MEP | milestone | 0d | 2019-05-08 | 2019-05-08 | 1F5-FNS-B05-1150, 1F5-FNS-B05-1170 | 83.5d | 0d | Arch'l | 3 | MB |
| RM80 |  | B05 . AREA-2 from Arch'l to MEP | milestone | 0d | 2019-06-30 | 2019-06-30 | 1F5-FNS-B05-1310, 1F5-FNS-B05-1300 | 38.5d | 0d | Arch'l | 2 | MB |
| RM90 |  | B05 . AREA-1 from Arch'l to MEP | milestone | 0d | 2019-07-17 | 2019-07-17 | 1F5-FNS-B05-3515, 1F5-FNS-B05-3480 | 27.25d | 0d | Arch'l | 1 | MB |
|  | 4 | **Technical Level (B04 )** |  |  | 2019-04-16 | 2019-07-04 |  |  |  |  |  |  |
| RM110 |  | B04. . AREA-5 from Arch'l to MEP | milestone | 0d | 2019-04-16 | 2019-04-16 | 1F5-FNS-B04-140a | 106.25d | 0d | Arch'l | 5 | MB |
| RM100 |  | B04. AREA-4 from Arch'l to MEP | milestone | 0d | 2019-05-02 | 2019-05-02 | 1F5-FNS-B04-360 | 96.25d | 0d | Arch'l | 4 | MB |
| RM120 |  | B04. . AREA-3 from Arch'l to MEP | milestone | 0d | 2019-05-22 | 2019-05-22 | 1F5-FNS-B04-575 | 82.5d | 0d | Arch'l | 3 | MB |
| RM130 |  | B04. . AREA-2 from Arch'l to MEP | milestone | 0d | 2019-06-15 | 2019-06-15 | 1F5-FNS-B04-795 | 68.75d | 0d | Arch'l | 2 | MB |
| RM140 |  | B04. . AREA-1 from Arch'l to MEP | milestone | 0d | 2019-07-04 | 2019-07-04 | 1F5-FNS-B04-1015 | 49.5d | 0d | Arch'l | 1 | MB |
|  | 5 | **Concourse Level (B03)** |  |  | 2019-03-17 | 2019-07-13 |  |  |  |  |  |  |
| RM160 |  | B03 . AREA-5 from Arch'l to MEP | milestone | 0d | 2019-03-17 | 2019-03-17 | 1F5-FNS-B03-070, 1F5-FNS-B03-040 | 97d | 0d | Arch'l | 5 | MB |
| RM150 |  | B03 . AREA-4 from Arch'l to MEP | milestone | 0d | 2019-05-02 | 2019-05-02 | 1F5-FNS-B03-200, 1F5-FNS-B03-170 | 47d | 0d | Arch'l | 4 | MB |
| RM170 |  | B03 . AREA-3 from Arch'l to MEP | milestone | 0d | 2019-06-15 | 2019-06-15 | 1F5-FNS-B03-330 | 61.25d | 0d | Arch'l | 3 | MB |
| RM180 |  | B03 . AREA-2 from Arch'l to MEP | milestone | 0d | 2019-06-29 | 2019-06-29 | 1F5-FNS-B03-460 | 1.5d | 0d | Arch'l | 2 | MB |
| RM190 |  | B03 . AREA-1 from Arch'l to MEP | milestone | 0d | 2019-07-13 | 2019-07-13 | 1F5-FNS-B03-540, 1F5-FNS-B03-590 | 39.75d | 0d | Arch'l | 1 | MB |
|  | 6 | **TV Louver Level (B02)** |  |  | 2019-05-16 | 2019-07-28 |  |  |  |  |  |  |
| RM210 |  | B02 . AREA-5 from Arch'l to MEP | milestone | 0d | 2019-05-16 | 2019-05-16 | 1F5-FNS-B02-040, 1F5-FNS-B02-070 | 97.25d | 0d | Arch'l | 5 | MB |
| RM200 |  | B02 . AREA-4 from Arch'l to MEP | milestone | 0d | 2019-05-30 | 2019-05-30 | 1F5-FNS-B02-170, 1F5-FNS-B02-200 | 82.25d | 0d | Arch'l | 4 | MB |
| RM220 |  | B02 . AREA-3 from Arch'l to MEP | milestone | 0d | 2019-07-14 | 2019-07-14 | 1F5-FNS-B02-310, 1F5-FNS-B02-340 | 37.5d | 0d | Arch'l | 3 | MB |
| RM230 |  | B02 . AREA-2 from Arch'l to MEP | milestone | 0d | 2019-07-25 | 2019-07-25 | 1F5-FNS-B02-470, 1F5-FNS-B02-440 | 26d | 0d | Arch'l | 2 | MB |
| RM240 |  | B02 . AREA-1 from Arch'l to MEP | milestone | 0d | 2019-07-28 | 2019-07-28 | 1F5-FNS-B02-570 | 14.5d | 0d | Arch'l | 1 | MB |

| ID | WBS | Activity | Type | Duration | Start | Finish | Predecessors | Total float | Free float | Discipline | AREA | LOCATION |
| --- | --- | --- | --- | --- | --- | --- | --- | --- | --- | --- | --- | --- |
|  | 7 | **Top Slab Level (B01)** |  |  | 2019-05-16 | 2019-08-14 |  |  |  |  |  |  |
| RM260 |  | B01 . AREA-5 from Arch'l to MEP | milestone | 0d | 2019-05-16 | 2019-05-16 | 1F5-FNS-B02-070 | 97.25d | 0d | Arch'l | 5 | MB |
| RM250 |  | B01 . AREA-4 from Arch'l to MEP | milestone | 0d | 2019-05-30 | 2019-05-30 | 1F5-FNS-B02-200 | 82.25d | 0d | Arch'l | 4 | MB |
| RM270 |  | B01 . AREA-3 from Arch'l to MEP | milestone | 0d | 2019-07-14 | 2019-07-14 | 1F5-FNS-B02-340 | 37.5d | 0d | Arch'l | 3 | MB |
| RM280 |  | B01 . AREA-2 from Arch'l to MEP | milestone | 0d | 2019-07-25 | 2019-07-25 | 1F5-FNS-B02-470 | 26d | 0d | Arch'l | 2 | MB |
| RM290 |  | B01 . AREA-1 from Arch'l to MEP | milestone | 0d | 2019-08-14 | 2019-08-14 | 1F5-FNS-B02-600 | -0.5d | 0d | Arch'l | 1 | MB |
|  | 2 | **FROM MEP TEAM BACK TO WET FINISHES TEAM** |  |  | 2019-04-22 | 2019-11-21 |  |  |  |  |  |  |
|  | 1 | **Base Raft (B07)** |  |  | 2019-06-17 | 2019-09-10 |  |  |  |  |  |  |
| MR610 |  | B07 . AREA-5 from MEP to ARCH'L | milestone | 0d | 2019-06-17 | 2019-06-17 | A6822, A6592, A7022, A6732, A8982, A8752, A9182, A8892 | 172.25d | 55d | MEP | 5 | MB |
| MR600 |  | B07 . AREA-4 from MEP to ARCH'L | milestone | 0d | 2019-07-31 | 2019-07-31 | 09, 28, 43, 53, A4662, A4432, A4862, A4572, LOE-SUM3-010 FF | 117.25d | 0d | MEP | 4 | MB |
| MR630 |  | B07 . AREA-2 from MEP to ARCH'L | milestone | 0d | 2019-08-07 | 2019-08-07 | A21942, A21712, A22142, A21852, A24102, A23872, A24302, A24012 | 117.25d | 55d | MEP | 2 | MB |
| MR640 |  | B07 . AREA-1 from MEP to ARCH'L | milestone | 0d | 2019-08-13 | 2019-08-13 | A17622, A17392, A17822, A17532, A19782, A19552, A19982, A19692, LOE-SUM3-050 FF | 153.25d | 60d | MEP | 1 | MB |
| MR620 |  | B07 . AREA-3 from MEP to ARCH'L | milestone | 0d | 2019-09-10 | 2019-09-10 | A11142, A10912, A11342, A11052, A13302, A13072, A13502, A13212, A15462, A15232, A15662, A15372, LOE-SUM3-030 FF | 77.25d | 15d | MEP | 3 | MB |
|  | 2 | **Platform Level (P06 )** |  |  | 2019-04-22 | 2019-09-17 |  |  |  |  |  |  |
| MR305 |  | P06 . AREA-4 Siemens Rm - from MEP to ARCH'L | milestone | 0d | 2019-04-22 | 2019-04-22 | A26262, A26032, A26502, A26172 | 19.25d | 0d | MEP | 4 | MB |
| MR315 |  | P06 . AREA-5 Siemens Rm - from MEP to ARCH'L | milestone | 0d | 2019-05-01 | 2019-05-01 | A28422, A28192, A28622, A28332, LOE-SUM3-070 FF | 1d | 0d | MEP | 5 | MB |
| MR325 |  | P06 . AREA-3 Siemens Rm - from MEP to ARCH'L | milestone | 0d | 2019-05-06 | 2019-05-06 | A32742, A32512, A32942 FF, A32652, LOE-SUM3-100 FF | 5.5d | 0d | MEP | 3 | MB |
| MR335 |  | P06 . AREA-2 Siemens Rm - from MEP to ARCH'L | milestone | 0d | 2019-05-16 | 2019-05-16 | A39222, A38992, A39422, A39132 | 23.5d | 0d | MEP | 2 | MB |
| MR345 |  | P06 . AREA-1 Siemens Rm - from MEP to ARCH'L | milestone | 0d | 2019-05-25 | 2019-05-25 | A37062, A36832, A37262, A36972, LOE-SUM3-130 FF | 14.25d | 0d | MEP | 1 | MB |
| MR300 |  | P06 . AREA-4 from MEP to ARCH'L | milestone | 0d | 2019-06-17 | 2019-06-17 | A30582, A30352, A30782, A30492 | 157.25d | 0d | MEP | 4 | MB |
| MR310 |  | P06 . AREA-5 from MEP to ARCH'L | milestone | 0d | 2019-06-17 | 2019-06-17 | A30582, A30352, A30782, A30492 | 164.75d | 47.5d | MEP | 5 | MB |
| MR330 |  | P06 . AREA-2 from MEP to ARCH'L | milestone | 0d | 2019-08-20 | 2019-08-20 | A41382, A41152, A41582, A41292 | 99.75d | 0d | MEP | 2 | MB |
| MR340 |  | P06 . AREA-1 from MEP to ARCH'L | milestone | 0d | 2019-08-20 | 2019-08-20 | A41382, A41152, A41582, A41292 | 138.25d | 0d | MEP | 1 | MB |
| MR320 |  | P06 . AREA-3 from MEP to ARCH'L | milestone | 0d | 2019-09-17 | 2019-09-17 | A34902, A34672, A35102, A34812 | 62.25d | 0d | MEP | 3 | MB |

| ID | WBS | Activity | Type | Duration | Start | Finish | Predecessors | Total float | Free float | Discipline | AREA | LOCATION |
| --- | --- | --- | --- | --- | --- | --- | --- | --- | --- | --- | --- | --- |
|  | 3 | **Mezzanine Level (B05)** |  |  | 2019-06-12 | 2019-10-28 |  |  |  |  |  |  |
| MR360 |  | B05 . AREA-5 from MEP to ARCH'L | milestone | 0d | 2019-06-12 | 2019-06-12 | A84933, A84910, A84953, A84924 | 139.75d | 0d | MEP | 5 | MB |
| MR350 |  | B05 . AREA-4 from MEP to ARCH'L | milestone | 0d | 2019-07-02 | 2019-07-02 | A84879, A84856, A84899, A84870, LOE-SUM3-160 FF | 126d | 0d | MEP | 4 | MB |
| MR370 |  | B05 . AREA-3 from MEP to ARCH'L | milestone | 0d | 2019-08-21 | 2019-08-21 | A84987, A84964, A85007, A84978, LOE-SUM3-180 FF | 83.5d | 0d | MEP | 3 | MB |
| MR380 |  | B05 . AREA-2 from MEP to ARCH'L | milestone | 0d | 2019-10-10 | 2019-10-10 | A85041, A85018, A85061, A85032 | 38.5d | 0d | MEP | 2 | MB |
| MR390 |  | B05 . AREA-1 from MEP to ARCH'L | milestone | 0d | 2019-10-28 | 2019-10-28 | A85095, A85072, A85115, A85086, LOE-SUM3-200 FF | 27.25d | 0d | MEP | 1 | MB |
|  | 4 | **Technical Level (B04 )** |  |  | 2019-07-27 | 2019-10-15 |  |  |  |  |  |  |
| MR410 |  | B04. . AREA-5 from MEP to ARCH'L | milestone | 0d | 2019-07-27 | 2019-07-27 | A45702, A45472, A45902, A45612 | 106.25d | 0d | MEP | 5 | MB |
| MR400 |  | B04. AREA-4 from MEP to ARCH'L | milestone | 0d | 2019-08-15 | 2019-08-15 | A43542, A43312, A43742, A43452, LOE-SUM3-220 FF | 96.25d | 0d | MEP | 4 | MB |
| MR420 |  | B04. . AREA-3 from MEP to ARCH'L | milestone | 0d | 2019-09-04 | 2019-09-04 | A47862, A47632, A48062, A47772, LOE-SUM3-240 FF | 82.5d | 0d | MEP | 3 | MB |
| MR430 |  | B04. . AREA-2 from MEP to ARCH'L | milestone | 0d | 2019-09-25 | 2019-09-25 | A50022, A49792, A50222, A49932 | 68.75d | 0d | MEP | 2 | MB |
| MR440 |  | B04. . AREA-1 from MEP to ARCH'L | milestone | 0d | 2019-10-15 | 2019-10-15 | A52182, A51952, A52382, A52092, LOE-SUM3-260 FF | 49.5d | 0d | MEP | 1 | MB |
|  | 5 | **Concourse Level (B03)** |  |  | 2019-06-26 | 2019-10-23 |  |  |  |  |  |  |
| MR460 |  | B03 . AREA-5 from MEP to ARCH'L | milestone | 0d | 2019-06-26 | 2019-06-26 | A56502, A56272, A56702, A56412 | 162.25d | 0d | MEP | 5 | MB |
| MR450 |  | B03 . AREA-4 from MEP to ARCH'L | milestone | 0d | 2019-08-15 | 2019-08-15 | A54342, A54112, A54542, A54252, LOE-SUM3-280 FF | 96.25d | 0d | MEP | 4 | MB |
| MR470 |  | B03 . AREA-3 from MEP to ARCH'L | milestone | 0d | 2019-09-25 | 2019-09-25 | A58662, A58432, A58862, A58572, LOE-SUM3-300 FF | 61.25d | 0d | MEP | 3 | MB |
| MR480 |  | B03 . AREA-2 from MEP to ARCH'L | milestone | 0d | 2019-10-09 | 2019-10-09 | A62982, A62752, A63182, A62892 | 53.75d | 0d | MEP | 2 | MB |
| MR490 |  | B03 . AREA-1 from MEP to ARCH'L | milestone | 0d | 2019-10-23 | 2019-10-23 | A60822, A60592, A61022, A60732, LOE-SUM3-320 FF | 39.75d | 0d | MEP | 1 | MB |
|  | 6 | **TV Louver Level (B02)** |  |  | 2019-08-29 | 2019-11-07 |  |  |  |  |  |  |
| MR510 |  | B02 . AREA-5 from MEP to ARCH'L | milestone | 0d | 2019-08-29 | 2019-08-29 | A67302, A67072, A67502, A67212 | 97.25d | 0d | MEP | 5 | MB |
| MR500 |  | B02 . AREA-4 from MEP to ARCH'L | milestone | 0d | 2019-09-12 | 2019-09-12 | A65142, A64912, A65342, A65052, A67302, A67072, A67502, A67212, LOE-SUM3-340 FF | 82.25d | 0d | MEP | 4 | MB |
| MR520 |  | B02 . AREA-3 from MEP to ARCH'L | milestone | 0d | 2019-10-24 | 2019-10-24 | A69462, A69232, A69662, A69372, LOE-SUM3-360 FF | 37.5d | 0d | MEP | 3 | MB |
| MR530 |  | B02 . AREA-2 from MEP to ARCH'L | milestone | 0d | 2019-11-05 | 2019-11-05 | A73782, A73552, A73982, A73692 | 26d | 0d | MEP | 2 | MB |
| MR540 |  | B02 . AREA-1 from MEP to ARCH'L | milestone | 0d | 2019-11-07 | 2019-11-07 | A71622, A71392, A71822, A71532, LOE-SUM3-380 FF | 14.5d | 15d | MEP | 1 | MB |

| ID | WBS | Activity | Type | Duration | Start | Finish | Predecessors | Total float | Free float | Constraint | Resources | Cost | Discipline | AREA | LOCATION |
| --- | --- | --- | --- | --- | --- | --- | --- | --- | --- | --- | --- | --- | --- | --- | --- |
|  | 7 | **Top Slab Level (B01)** |  |  | 2019-08-29 | 2019-11-21 |  |  |  |  |  |  |  |  |  |
| MR560 |  | B01 . AREA-5 from MEP to ARCH'L | milestone | 0d | 2019-08-29 | 2019-08-29 | A78102, A77872, A78302, A78012 | 97.25d | 0d |  |  |  | MEP | 5 | MB |
| MR550 |  | B01 . AREA-4 from MEP to ARCH'L | milestone | 0d | 2019-09-12 | 2019-09-12 | A75942, A75712, A76142, A75852 | 82.25d | 0d |  |  |  | MEP | 4 | MB |
| MR570 |  | B01 . AREA-3 from MEP to ARCH'L | milestone | 0d | 2019-10-24 | 2019-10-24 | A80262, A80032, A80462, A80172 | 37.5d | 0d |  |  |  | MEP | 3 | MB |
| MR580 |  | B01 . AREA-2 from MEP to ARCH'L | milestone | 0d | 2019-11-05 | 2019-11-05 | A84582, A84352, A84782, A84492 | 26d | 0d |  |  |  | MEP | 2 | MB |
| MR590 |  | B01 . AREA-1 from MEP to ARCH'L | milestone | 0d | 2019-11-21 | 2019-11-21 | A82422, A82192, A82622, A82332, LOE-SUM3-400 FF | -0.5d | 0d |  |  |  | MEP | 1 | MB |
|  | 9 | **PROJECT MANAGEMENT** |  |  | 2018-08-29 | 2020-09-12 |  |  |  |  |  |  |  |  |  |
| PRO-010 |  | LOE - Project Management & supervision + Safety | level of effort | 782.25d | 2018-08-29 | 2020-09-12 | MOB1F5010 SS | 2.5d | 0d |  | 1F5-Management [156450 h] |  |  |  |  |
| PRO-020 |  | LOE - Rigger | level of effort | 772.25d | 2018-08-29 | 2020-09-02 | MOB1F5030 SS | 6.25d | 0d |  | 1F5-Riggers [154450 h] | 10,857.84 | Civil |  |  |
| PRO-030 |  | LOE - Scaffolder | level of effort | 764.75d | 2018-09-01 | 2020-08-29 | C1C1111F5S330 SS | 0d |  |  | 1F5-Scaffolders [91770 h] | 6,451.43 | Civil |  |  |
|  | 2 | **MOBILIZATION** |  |  | 2018-08-29 | 2018-10-02 |  |  |  |  |  |  |  |  |  |
| MOB1F5010 |  | Manpower & Equipment Mobilization |  | 37.5d | 2018-08-29 | 2018-10-02 |  | 0d |  |  | 1F5-MOB [3500 h] | 1,608.25 |  |  |  |
| MOB1F5030 |  | Temporary Site office development |  | 32.5d | 2018-08-29 | 2018-09-27 | MOB1F5010 SS | 2.5d |  |  | 1F5-MOB [3200 h] | 1,470.4 |  |  |  |
|  | 3 | **ENGINEERING / SHOP DRAWINGS** |  |  | 2018-08-29 | 2019-03-14 |  |  |  |  |  |  |  |  |  |
|  | 1 | **CIVIL SHOP DWG SUBMITALS (Bar Bending Sched -BBS)** |  |  | 2018-10-20 | 2019-01-10 |  |  |  |  |  |  |  |  |  |
|  | 1 | **Submittal of CIVIL SHOP DWG (Bar Bending Sched -BBS for MAIN BOX)** |  |  | 2018-10-20 | 2019-01-10 |  |  |  |  |  |  |  |  |  |
|  | 1 | **BBS for Technical Level (B04 )** |  |  | 2018-10-20 | 2018-11-01 |  |  |  |  |  |  |  |  |  |
| B150 |  | B04 . AREA-4 BBS dwg preparation & submittal |  | 7.5d | 2018-10-20 | 2018-10-25 | MOB1F5030 | -6.25d | 0d | start on or after 2018-10-20 |  |  |  | 4 |  |
| B160 |  | B04 . AREA-5BBS dwg preparation & submittal |  | 7.5d | 2018-10-20 | 2018-10-25 | B150 SS | 8.25d | 0d |  |  |  |  | 5 |  |
| B170 |  | B04 . AREA-3 BBS dwg preparation & submittal |  | 7.5d | 2018-10-27 | 2018-11-01 | B160 | 8.25d | 0d |  |  |  |  | 3 |  |
| B180 |  | B04 . AREA-2 BBS dwg preparation & submittal |  | 7.5d | 2018-10-27 | 2018-11-01 | B170 SS | 8.25d | 0d |  |  |  |  | 2 |  |
| B190 |  | B04 . AREA-1 BBS dwg preparation & submittal |  | 7.5d | 2018-10-27 | 2018-11-01 | B180 SS | 8.25d | 0d |  |  |  |  | 1 |  |
|  | 2 | **BBS for Concourse Level (B03)** |  |  | 2018-11-03 | 2018-11-15 |  |  |  |  |  |  |  |  |  |
| B200 |  | B03 . AREA-4 BBS dwg preparation & submittal |  | 7.5d | 2018-11-03 | 2018-11-08 | B190 | 8.25d | 0d |  |  |  |  | 4 |  |
| B210 |  | B03 . AREA-5BBS dwg preparation & submittal |  | 7.5d | 2018-11-03 | 2018-11-08 | B200 SS | 30.75d | 0d |  |  |  |  | 5 |  |
| B220 |  | B03 . AREA-3 BBS dwg preparation & submittal |  | 7.5d | 2018-11-10 | 2018-11-15 | B210 | 30.75d | 0d |  |  |  |  | 3 |  |
| B230 |  | B03 . AREA-2 BBS dwg preparation & submittal |  | 7.5d | 2018-11-10 | 2018-11-15 | B220 SS | 30.75d | 0d |  |  |  |  | 2 |  |
| B240 |  | B03 . AREA-1 BBS dwg preparation & submittal |  | 7.5d | 2018-11-10 | 2018-11-15 | B230 SS | 30.75d | 0d |  |  |  |  | 1 |  |

| ID | WBS | Activity | Duration | Start | Finish | Predecessors | Total float | Free float | Constraint | AREA |
| --- | --- | --- | --- | --- | --- | --- | --- | --- | --- | --- |
|  | 3 | **BBS for TV Louver Level (B02)** |  | 2018-11-17 | 2018-11-29 |  |  |  |  |  |
| B250 |  | B02 . AREA-4 BBS dwg preparation & submittal | 7.5d | 2018-11-17 | 2018-11-22 | B240 | 30.75d | 0d |  | 4 |
| B260 |  | B02 . AREA-5BBS dwg preparation & submittal | 7.5d | 2018-11-17 | 2018-11-22 | B250 SS | 53.75d | 0d |  | 5 |
| B270 |  | B02 . AREA-3 BBS dwg preparation & submittal | 7.5d | 2018-11-24 | 2018-11-29 | B260 | 53.75d | 0d |  | 3 |
| B280 |  | B02 . AREA-2 BBS dwg preparation & submittal | 7.5d | 2018-11-24 | 2018-11-29 | B270 SS | 53.75d | 0d |  | 2 |
| B290 |  | B02 . AREA-1 BBS dwg preparation & submittal | 7.5d | 2018-11-24 | 2018-11-29 | B280 SS | 53.75d | 0d |  | 1 |
|  | 4 | **BBS for Top Slab Level (B01)** |  | 2018-12-22 | 2019-01-10 |  |  |  |  |  |
| B300 |  | B01 . AREA-4 BBS dwg preparation & submittal | 7.5d | 2018-12-22 | 2018-12-27 | B290 FS+22.5d | 53.75d | 0d |  | 4 |
| B310 |  | B01 . AREA-5BBS dwg preparation & submittal | 7.5d | 2018-12-29 | 2019-01-03 | B300 | 75.75d | 0d |  | 5 |
| B320 |  | B01 . AREA-3 BBS dwg preparation & submittal | 7.5d | 2019-01-05 | 2019-01-10 | B310 | 75.75d | 0d |  | 3 |
| B330 |  | B01 . AREA-2 BBS dwg preparation & submittal | 7.5d | 2019-01-05 | 2019-01-10 | B320 SS | 90.75d | 0d |  | 2 |
| B340 |  | B01 . AREA-1 BBS dwg preparation & submittal | 7.5d | 2019-01-05 | 2019-01-10 | B330 SS | 115.75d | 0d |  | 1 |
|  | 2 | **Submittal of CIVIL SHOP DWG (Bar Bending Sched -BBS for ENTRANCES)** |  | 2018-10-20 | 2018-11-01 |  |  |  |  |  |
| B350 |  | B04 . ENTRANCES BBS dwg preparation & submittal | 7.5d | 2018-10-20 | 2018-10-25 | B150 SS | -6.25d | 0d | start on or after 2018-10-20 |  |
| B360 |  | B03 . ENTRANCES BBS dwg preparation & submittal | 7.5d | 2018-10-20 | 2018-10-25 | B350 SS | 15d | 0d |  |  |
| B370 |  | B02 . ENTRANCES BBS dwg preparation & submittal | 7.5d | 2018-10-27 | 2018-11-01 | B360 | 15d | 0d |  |  |
| B380 |  | B01 . ENTRANCES BBS dwg preparation & submittal | 7.5d | 2018-10-27 | 2018-11-01 | B370 SS | 16.25d | 0d |  |  |
| B390 |  | B01 . ENTRANCES Paraphet wall BBS dwg preparation & submittal | 7.5d | 2018-10-27 | 2018-11-01 | B380 SS | 16.25d | 0d |  |  |
|  | 3 | **Submittal of CIVIL SHOP DWG (Bar Bending Sched -BBS for ACY)** |  | 2018-11-03 | 2018-11-29 |  |  |  |  |  |
| B410 |  | B03 . ACY BBS dwg preparation & submittal | 7.5d | 2018-11-03 | 2018-11-08 | B390 | 16.25d | 0d |  |  |
| B420 |  | B02 . ACY BBS dwg preparation & submittal | 7.5d | 2018-11-24 | 2018-11-29 | B410 FS+15d | 106.25d | 0d |  |  |
| B430 |  | B01 . ACY BBS dwg preparation & submittal | 7.5d | 2018-11-24 | 2018-11-29 | B420 SS | 106.25d | 0d |  |  |
| B440 |  | B01 . ACY Paraphet wall BBS dwg preparation & submittal | 7.5d | 2018-11-24 | 2018-11-29 | B430 SS | 106.25d | 0d |  |  |
|  | 2 | **CIVIL SHOP DRAWING APPROVAL (Bar Bending Sched -BBS)** |  | 2018-10-27 | 2019-01-17 |  |  |  |  |  |
|  | 1 | **Approval of CIVIL SHOP DWG (Bar Bending Sched -BBS for MAIN BOX)** |  | 2018-10-27 | 2019-01-17 |  |  |  |  |  |
|  | 1 | **BBS for Technical Level (B04 )** |  | 2018-10-27 | 2018-11-08 |  |  |  |  |  |
| B500 |  | B04 . AREA-4 BBS dwg - Review & Approval | 7.5d | 2018-10-27 | 2018-11-01 | B150 | 14.5d | 0d |  | 4 |
| B510 |  | B04 . AREA-5 BBS dwg - Review & Approval | 7.5d | 2018-10-27 | 2018-11-01 | B500 SS | 28.75d | 0d |  | 5 |
| B520 |  | B04 . AREA-3 BBS dwg - Review & Approval | 7.5d | 2018-11-03 | 2018-11-08 | B170, B510 | 40.75d | 0d |  | 3 |
| B530 |  | B04 . AREA-2 BBS dwg - Review & Approval | 7.5d | 2018-11-03 | 2018-11-08 | B520 SS | 75.75d | 0d |  | 2 |
| B540 |  | B04 . AREA-1 BBS dwg - Review & Approval | 7.5d | 2018-11-03 | 2018-11-08 | B530 SS | 77.5d | 80d |  | 1 |

| ID | WBS | Activity | Duration | Start | Finish | Predecessors | Total float | Free float | AREA |
| --- | --- | --- | --- | --- | --- | --- | --- | --- | --- |
|  | 2 | **BBS for Concourse Level (B03)** |  | 2018-11-10 | 2018-11-22 |  |  |  |  |
| B550 |  | B03 . AREA-4 BBS dwg - Review & Approval | 7.5d | 2018-11-10 | 2018-11-15 | B200 | 8.25d | 0d | 4 |
| B560 |  | B03 . AREA-5 BBS dwg - Review & Approval | 7.5d | 2018-11-10 | 2018-11-15 | B550 SS | 19d | 0d | 5 |
| B570 |  | B03 . AREA-3 BBS dwg - Review & Approval | 7.5d | 2018-11-17 | 2018-11-22 | B560, B220 | 58.25d | 0d | 3 |
| B580 |  | B03 . AREA-2 BBS dwg - Review & Approval | 7.5d | 2018-11-17 | 2018-11-22 | B570 SS | 100.75d | 0d | 2 |
| B590 |  | B03 . AREA-1 BBS dwg - Review & Approval | 7.5d | 2018-11-17 | 2018-11-22 | B580 SS | 105.75d | 105d | 1 |
|  | 3 | **BBS for TV Louver Level (B02)** |  | 2018-11-24 | 2018-12-06 |  |  |  |  |
| B600 |  | B02 . AREA-4 BBS dwg - Review & Approval | 7.5d | 2018-11-24 | 2018-11-29 | B250 | 30.75d | 0d | 4 |
| B610 |  | B02 . AREA-5 BBS dwg - Review & Approval | 7.5d | 2018-11-24 | 2018-11-29 | B600 SS | 45.75d | 0d | 5 |
| B620 |  | B02 . AREA-3 BBS dwg - Review & Approval | 7.5d | 2018-12-01 | 2018-12-06 | B270, B610 | 82d | 0d | 3 |
| B630 |  | B02 . AREA-2 BBS dwg - Review & Approval | 7.5d | 2018-12-01 | 2018-12-06 | B620 SS | 114.5d | 0d | 2 |
| B640 |  | B02 . AREA-1 BBS dwg - Review & Approval | 7.5d | 2018-12-01 | 2018-12-06 | B630 SS | 125.75d | 125d | 1 |
|  | 4 | **BBS for Top Slab Level (B01)** |  | 2018-12-29 | 2019-01-17 |  |  |  |  |
| B650 |  | B01 . AREA-4 BBS dwg - Review & Approval | 7.5d | 2018-12-29 | 2019-01-03 | B300 | 53.75d | 0d | 4 |
| B660 |  | B01 . AREA-5 BBS dwg - Review & Approval | 7.5d | 2018-12-29 | 2019-01-03 | B650 SS | 56.25d | 7.5d | 5 |
| B670 |  | B01 . AREA-3 BBS dwg - Review & Approval | 7.5d | 2019-01-05 | 2019-01-10 | B660 SS, B320 SS | 75.75d | 0d | 3 |
| B680 |  | B01 . AREA-2 BBS dwg - Review & Approval | 7.5d | 2019-01-12 | 2019-01-17 | B330, B670 | 90.75d | 0d | 2 |
| B690 |  | B01 . AREA-1 BBS dwg - Review & Approval | 7.5d | 2019-01-12 | 2019-01-17 | B340, B680 SS | 115.75d | 115d | 1 |
|  | 2 | **Approval of CIVIL SHOP DWG (Bar Bending Sched -BBS for ENTRANCES)** |  | 2018-10-27 | 2018-11-08 |  |  |  |  |
| B700 |  | B04 . ENTRANCES BBS dwg Review & Approval | 7.5d | 2018-10-27 | 2018-11-01 | B350 | -6.25d | 0d |  |
| B710 |  | B03 . ENTRANCES BBS dwg Review & Approval | 7.5d | 2018-10-27 | 2018-11-01 | B700 SS | 15d | 0d |  |
| B720 |  | B02 . ENTRANCES BBS dwg Review & Approval | 7.5d | 2018-11-03 | 2018-11-08 | B370, B710 | 15d | 0d |  |
| B730 |  | B01 . ENTRANCES BBS dwg Review & Approval | 7.5d | 2018-11-03 | 2018-11-08 | B720 SS | 16.25d | 0d |  |
| B740 |  | B01 . ENTRANCES Paraphet wall BBS dwg Review & Approval | 7.5d | 2018-11-03 | 2018-11-08 | B730 SS | 16.25d | 0d |  |

| ID | WBS | Activity | Duration | Start | Finish | Predecessors | Total float | Free float | Constraint | 1F4 PROJECT | Discipline |
| --- | --- | --- | --- | --- | --- | --- | --- | --- | --- | --- | --- |
|  | 3 | **Approval of CIVIL SHOP DWG (Bar Bending Sched -BBS for ACY)** |  | 2018-11-10 | 2018-12-06 |  |  |  |  |  |  |
| B750 |  | B03 . ACY BBS dwg Review & Approval | 7.5d | 2018-11-10 | 2018-11-15 | B740, B410 | 16.25d | 10d |  |  |  |
| B770 |  | B02 . ACY BBS dwg Review & Approval | 7.5d | 2018-11-10 | 2018-11-15 | B740 | 103.75d | 0d |  |  |  |
| B780 |  | B01 . ACY BBS dwg Review & Approval | 7.5d | 2018-11-17 | 2018-11-22 | B770 | 121.25d | 15d |  |  |  |
| B790 |  | B01 . ACY Paraphet wall BBS dwg Review & Approval | 7.5d | 2018-12-01 | 2018-12-06 | B780 SS, B440 | 106.25d | 80d |  |  |  |
|  | 3 | **ARCH'L / FINISHES SHOP DWG** |  | 2018-10-20 | 2019-03-14 |  |  |  |  |  |  |
|  | 1 | **Submittal of ARCH'L SHOP DWG** |  | 2018-10-20 | 2019-01-28 |  |  |  |  |  |  |
|  | 1 | **Base Raft (B07) - Submittal of ARCH'L SHOP DWG** |  | 2018-10-20 | 2018-11-29 |  |  |  |  |  |  |
| 1F5-ARDWG010 |  | B07 - Block Masonry & Plastering Shop Dwg Submittals | 15d | 2018-10-20 | 2018-11-01 | B150 SS | 2.75d | 0d | start on or after 2018-10-20 | 1F4CVL | Arch'l |
| 1F5-ARDWG020 |  | B07 - Walls Finishing Shop Dwg Submittals | 15d | 2018-10-23 | 2018-11-05 | 1F5-ARDWG010 FF+3.75d | 2.75d | 0d |  | 1F4CVL | Arch'l |
| 1F5-ARDWG030 |  | B07 - Ceiling Finishing Shop Dwg Submittals | 15d | 2018-10-29 | 2018-11-11 | 1F5-ARDWG020 FF+6.25d | 5.25d | 0d |  | 1F4CVL | Arch'l |
| 1F5-ARDWG040 |  | B07 - Steel Structure Shop Dwg Submittals | 15d | 2018-11-03 | 2018-11-15 | 1F5-ARDWG010, 1F5-PRO-GN-010 SS | 73.5d | 0d |  | 1F4CVL | Arch'l |
| 1F5-ARDWG050 |  | B07 - Floors Finishing Shop Dwg Submittals | 15d | 2018-11-04 | 2018-11-17 | 1F5-ARDWG030 FF+6.25d | 5.25d | 0d |  | 1F4CVL | Arch'l |
| 1F5-ARDWG070 |  | B07 - Doors Shop Dwg Submittals | 15d | 2018-11-06 | 2018-11-19 | 1F5-ARDWG020, 1F5-ARDWG010, 1F5-ARDWG050 FF | 2.75d | 0d |  | 1F4CVL | Arch'l |
| 1F5-ARDWG060 |  | B07 - Walls Cladding Finishing Shop Dwg Submittals | 15d | 2018-11-17 | 2018-11-29 | 1F5-ARDWG020, 1F5-ARDWG040 | 224.75d | 0d |  | 1F4CVL | Arch'l |
|  | 2 | **Platform Level (P06 ) - Submittal of ARCH'L SHOP DWG** |  | 2018-10-20 | 2018-11-29 |  |  |  |  |  |  |
| 1F5-ARDWG075 |  | P06 - Block Masonry & Plastering Shop Dwg Submittals | 15d | 2018-10-20 | 2018-11-01 | 1F5-ARDWG010 SS | 17.75d | 0d |  | 1F4CVL | Arch'l |
| 1F5-ARDWG080 |  | P06 -Walls Finishing Shop Dwg Submittals | 15d | 2018-10-23 | 2018-11-05 | 1F5-ARDWG075 FF+3.75d | 17.75d | 0d |  | 1F4CVL | Arch'l |
| 1F5-ARDWG090 |  | P06 -Ceiling Finishing Shop Dwg Submittals | 15d | 2018-10-29 | 2018-11-11 | 1F5-ARDWG080 FF+6.25d | 20.25d | 0d |  | 1F4CVL | Arch'l |
| 1F5-ARDWG100 |  | P06 -Steel Structure Shop Dwg Submittals | 15d | 2018-11-03 | 2018-11-15 | 1F5-ARDWG075 | 88.5d | 0d |  | 1F4CVL | Arch'l |
| 1F5-ARDWG110 |  | P06 -Floors Finishing Shop Dwg Submittals | 15d | 2018-11-04 | 2018-11-17 | 1F5-ARDWG090 FF+6.25d | 20.25d | 2.5d |  | 1F4CVL | Arch'l |
| 1F5-ARDWG130 |  | P06 -Doors Shop Dwg Submittals | 15d | 2018-11-06 | 2018-11-19 | 1F5-ARDWG075, 1F5-ARDWG080, 1F5-ARDWG110 FF | 17.75d | 15d |  | 1F4CVL | Arch'l |
| 1F5-ARDWG120 |  | P06 -Walls Cladding Finishing Shop Dwg Submittals | 15d | 2018-11-17 | 2018-11-29 | 1F5-ARDWG080, 1F5-ARDWG100 | 239.75d | 15d |  | 1F4CVL | Arch'l |
|  | 3 | **Mezzanine Level (B05) - Submittal of ARCH'L SHOP DWG** |  | 2018-11-03 | 2018-12-03 |  |  |  |  |  |  |
| 1F5-ARDWG140 |  | B05 - Block Masonry & Plastering Shop Dwg Submittals | 15d | 2018-11-03 | 2018-11-15 | 1F5-ARDWG075 | 36.5d | 0d |  | 1F4CVL | Arch'l |
| 1F5-ARDWG150 |  | B05 - Walls Finishing Shop Dwg Submittals | 15d | 2018-11-06 | 2018-11-19 | 1F5-ARDWG140 FF+3.75d | 82.25d | 0d |  | 1F4CVL | Arch'l |
| 1F5-ARDWG160 |  | B05 - Ceiling Finishing Shop Dwg Submittals | 15d | 2018-11-12 | 2018-11-25 | 1F5-ARDWG150 FF+6.25d | 208.5d | 0d |  | 1F4CVL | Arch'l |
| 1F5-ARDWG180 |  | B05 - Steel Structure Shop Dwg Submittals | 15d | 2018-11-17 | 2018-11-29 | 1F5-ARDWG140 | 196d | 33.75d |  | 1F4CVL | Arch'l |
| 1F5-ARDWG170 |  | B05 - Floors Finishing Shop Dwg Submittals | 15d | 2018-11-18 | 2018-12-01 | 1F5-ARDWG160 FF+6.25d | 303.75d | 2.5d |  | 1F4CVL | Arch'l |
| 1F5-ARDWG190 |  | B05 - Walls Cladding Finishing Shop Dwg Submittals | 15d | 2018-11-20 | 2018-12-03 | 1F5-ARDWG150 | 206d | 33.75d |  | 1F4CVL | Arch'l |
| 1F5-ARDWG200 |  | B05 - Doors Shop Dwg Submittals | 15d | 2018-11-20 | 2018-12-03 | 1F5-ARDWG150, 1F5-ARDWG140, 1F5-ARDWG170 FF | 399.75d | 33.75d |  | 1F4CVL | Arch'l |

| ID | WBS | Activity | Duration | Start | Finish | Predecessors | Total float | Free float | 1F4 PROJECT | Discipline |
| --- | --- | --- | --- | --- | --- | --- | --- | --- | --- | --- |
|  | 4 | **Technical Level (B04 ) - Submittal of ARCH'L SHOP DWG** |  | 2018-11-17 | 2018-12-27 |  |  |  |  |  |
| 1F5-ARDWG210 |  | B04 - Block Masonry & Plastering Shop Dwg Submittals | 15d | 2018-11-17 | 2018-11-29 | 1F5-ARDWG140 | 36.5d | 0d | 1F4CVL | Arch'l |
| 1F5-ARDWG220 |  | B04 - Walls Finishing Shop Dwg Submittals | 15d | 2018-12-01 | 2018-12-13 | 1F5-ARDWG210 | 193.75d | 0d | 1F4CVL | Arch'l |
| 1F5-ARDWG250 |  | B04 - Steel Structure Shop Dwg Submittals | 15d | 2018-12-01 | 2018-12-13 | 1F5-ARDWG210 | 195d | 33.75d | 1F4CVL | Arch'l |
| 1F5-ARDWG230 |  | B04 - Ceiling Finishing Shop Dwg Submittals | 15d | 2018-12-06 | 2018-12-19 | 1F5-ARDWG220 FF+6.25d | 304d | 0d | 1F4CVL | Arch'l |
| 1F5-ARDWG240 |  | B04 - Floors Finishing Shop Dwg Submittals | 15d | 2018-12-12 | 2018-12-25 | 1F5-ARDWG230 FF+6.25d | 376d | 2.5d | 1F4CVL | Arch'l |
| 1F5-ARDWG260 |  | B04 - Walls Cladding Finishing Shop Dwg Submittals | 15d | 2018-12-15 | 2018-12-27 | 1F5-ARDWG220 | 193.75d | 22.5d | 1F4CVL | Arch'l |
| 1F5-ARDWG270 |  | B04 - Doors Shop Dwg Submittals | 15d | 2018-12-15 | 2018-12-27 | 1F5-ARDWG210, 1F5-ARDWG240 FF, 1F5-ARDWG220 | 373.5d | 22.5d | 1F4CVL | Arch'l |
|  | 5 | **Concourse Level (B03) - Submittal of ARCH'L SHOP DWG** |  | 2018-12-01 | 2018-12-31 |  |  |  |  |  |
| 1F5-ARDWG280 |  | B03- Block Masonry & Plastering Shop Dwg Submittals | 15d | 2018-12-01 | 2018-12-13 | 1F5-ARDWG210 | 36.5d | 0d | 1F4CVL | Arch'l |
| 1F5-ARDWG290 |  | B03- Walls Finishing Shop Dwg Submittals | 15d | 2018-12-04 | 2018-12-17 | 1F5-ARDWG280 FF+3.75d | 41.5d | 0d | 1F4CVL | Arch'l |
| 1F5-ARDWG300 |  | B03- Ceiling Finishing Shop Dwg Submittals | 15d | 2018-12-10 | 2018-12-23 | 1F5-ARDWG290 FF+6.25d | 55.25d | 0d | 1F4CVL | Arch'l |
| 1F5-ARDWG320 |  | B03- Steel Structure Shop Dwg Submittals | 15d | 2018-12-15 | 2018-12-27 | 1F5-ARDWG280 | 42.75d | 33.75d | 1F4CVL | Arch'l |
| 1F5-ARDWG310 |  | B03- Floors Finishing Shop Dwg Submittals | 15d | 2018-12-16 | 2018-12-29 | 1F5-ARDWG300 FF+6.25d | 311.25d | 2.5d | 1F4CVL | Arch'l |
| 1F5-ARDWG330 |  | B03- Walls Cladding Finishing Shop Dwg Submittals | 15d | 2018-12-18 | 2018-12-31 | 1F5-ARDWG290 | 52.75d | 33.75d | 1F4CVL | Arch'l |
| 1F5-ARDWG340 |  | B03- Doors Shop Dwg Submittals | 15d | 2018-12-18 | 2018-12-31 | 1F5-ARDWG290, 1F5-ARDWG310 FF, 1F5-ARDWG280 | 369.75d | 33.75d | 1F4CVL | Arch'l |
|  | 6 | **TV Louver Level (B02) ) - Submittal of ARCH'L SHOP DWG** |  | 2018-12-15 | 2019-01-14 |  |  |  |  |  |
| 1F5-ARDWG350 |  | B02- Block Masonry & Plastering Shop Dwg Submittals | 15d | 2018-12-15 | 2018-12-27 | 1F5-ARDWG280 | 85.75d | 0d | 1F4CVL | Arch'l |
| 1F5-ARDWG360 |  | B02- Walls Finishing Shop Dwg Submittals | 15d | 2018-12-18 | 2018-12-31 | 1F5-ARDWG350 FF+3.75d | 187.25d | 0d | 1F4CVL | Arch'l |
| 1F5-ARDWG370 |  | B02- Ceiling Finishing Shop Dwg Submittals | 15d | 2018-12-24 | 2019-01-06 | 1F5-ARDWG360 FF+6.25d | 296.25d | 0d | 1F4CVL | Arch'l |
| 1F5-ARDWG390 |  | B02- Steel Structure Shop Dwg Submittals | 15d | 2018-12-29 | 2019-01-10 | 1F5-ARDWG350 | 346d | 33.75d | 1F4CVL | Arch'l |
| 1F5-ARDWG380 |  | B02- Floors Finishing Shop Dwg Submittals | 15d | 2018-12-30 | 2019-01-12 | 1F5-ARDWG370 FF+6.25d | 296.25d | 2.5d | 1F4CVL | Arch'l |
| 1F5-ARDWG400 |  | B02- Walls Cladding Finishing Shop Dwg Submittals | 15d | 2019-01-01 | 2019-01-14 | 1F5-ARDWG360 | 198.5d | 33.75d | 1F4CVL | Arch'l |
| 1F5-ARDWG410 |  | B02- Doors Shop Dwg Submittals | 15d | 2019-01-01 | 2019-01-14 | 1F5-ARDWG350, 1F5-ARDWG360, 1F5-ARDWG380 FF | 342.25d | 33.75d | 1F4CVL | Arch'l |

| ID | WBS | Activity | Duration | Start | Finish | Predecessors | Total float | Free float | 1F4 PROJECT | Discipline |
| --- | --- | --- | --- | --- | --- | --- | --- | --- | --- | --- |
|  | 7 | **Top Slab Level (B01) - Submittal of ARCH'L SHOP DWG** |  | 2018-12-29 | 2019-01-28 |  |  |  |  |  |
| 1F5-ARDWG420 |  | B01- Block Masonry & Plastering Shop Dwg Submittals | 15d | 2018-12-29 | 2019-01-10 | 1F5-ARDWG010, 1F5-ARDWG350 | 158.25d | 0d | 1F4CVL | Arch'l |
| 1F5-ARDWG430 |  | B01- Walls Finishing Shop Dwg Submittals | 15d | 2019-01-01 | 2019-01-14 | 1F5-ARDWG420 FF+3.75d | 163.25d | 0d | 1F4CVL | Arch'l |
| 1F5-ARDWG440 |  | B01- Ceiling Finishing Shop Dwg Submittals | 15d | 2019-01-07 | 2019-01-20 | 1F5-ARDWG430 FF+6.25d | 177d | 0d | 1F4CVL | Arch'l |
| 1F5-ARDWG460 |  | B01- Steel Structure Shop Dwg Submittals | 15d | 2019-01-12 | 2019-01-24 | 1F5-ARDWG420 | 164.5d | 33.75d | 1F4CVL | Arch'l |
| 1F5-ARDWG450 |  | B01- Floors Finishing Shop Dwg Submittals | 15d | 2019-01-13 | 2019-01-26 | 1F5-ARDWG440 FF+6.25d | 272.25d | 2.5d | 1F4CVL | Arch'l |
| 1F5-ARDWG470 |  | B01- Walls Cladding Finishing Shop Dwg Submittals | 15d | 2019-01-15 | 2019-01-28 | 1F5-ARDWG430 | 174.5d | 33.75d | 1F4CVL | Arch'l |
| 1F5-ARDWG480 |  | B01- Doors Shop Dwg Submittals | 15d | 2019-01-15 | 2019-01-28 | 1F5-ARDWG420, 1F5-ARDWG450 FF, 1F5-ARDWG430 | 327.25d | 33.75d | 1F4CVL | Arch'l |
|  | 2 | **Approval of ARCH'L SHOP DWG** |  | 2018-11-03 | 2019-03-14 |  |  |  |  |  |
|  | 1 | **Base Raft (B07) - Approval of ARCH'L SHOP DWG** |  | 2018-11-03 | 2018-12-13 |  |  |  |  |  |
| 1F5-ARDWG490 |  | B07 - Block Masonry & Plastering Shop Dwg Approval | 15d | 2018-11-03 | 2018-11-15 | 1F5-ARDWG010 | 2.75d | 0d | 1F4CVL | Arch'l |
| 1F5-ARDWG500 |  | B07 - Walls Finishing Shop Dwg Approval | 15d | 2018-11-06 | 2018-11-19 | 1F5-ARDWG020, 1F5-ARDWG490 FF+3.75d | 2.75d | 0d | 1F4CVL | Arch'l |
| 1F5-ARDWG510 |  | B07 - Ceiling Finishing Shop Dwg Approval | 15d | 2018-11-12 | 2018-11-25 | 1F5-ARDWG500 FF+6.25d, 1F5-ARDWG030 | 5.25d | 0d | 1F4CVL | Arch'l |
| 1F5-ARDWG530 |  | B07 - Steel Structure Shop Dwg Approval | 15d | 2018-11-17 | 2018-11-29 | 1F5-ARDWG040, 1F5-ARDWG490 | 73.5d | 0d | 1F4CVL | Arch'l |
| 1F5-ARDWG520 |  | B07 - Floors Finishing Shop Dwg Approval | 15d | 2018-11-18 | 2018-12-01 | 1F5-ARDWG050, 1F5-ARDWG510 FF+6.25d | 5.25d | 0d | 1F4CVL | Arch'l |
| 1F5-ARDWG550 |  | B07 - Doors Shop Dwg Approval | 15d | 2018-11-20 | 2018-12-03 | 1F5-ARDWG490, 1F5-ARDWG520 FF, 1F5-ARDWG070, 1F5-ARDWG500 | 2.75d | 0d | 1F4CVL | Arch'l |
| 1F5-ARDWG540 |  | B07 - Walls Cladding Finishing Shop Dwg Approval | 15d | 2018-12-01 | 2018-12-13 | 1F5-ARDWG060, 1F5-ARDWG500 | 224.75d | 0d | 1F4CVL | Arch'l |
|  | 2 | **Platform Level (P06 ) - Approval of ARCH'L SHOP DWG** |  | 2018-11-03 | 2018-12-27 |  |  |  |  |  |
| 1F5-ARDWG560 |  | P06 - Block Masonry & Plastering Shop Dwg Approval | 15d | 2018-11-03 | 2018-11-15 | 1F5-ARDWG075 | 17.75d | 15d | 1F4CVL | Arch'l |
| 1F5-ARDWG570 |  | P06 - Walls Finishing Shop Dwg Approval | 15d | 2018-11-20 | 2018-12-03 | 1F5-ARDWG560 FF+3.75d, 1F5-ARDWG080, 1F5-ARDWG500 | 2.75d | 0d | 1F4CVL | Arch'l |
| 1F5-ARDWG580 |  | P06 - Ceiling Finishing Shop Dwg Approval | 15d | 2018-11-26 | 2018-12-09 | 1F5-ARDWG090, 1F5-ARDWG570 FF+6.25d, 1F5-ARDWG510 | 5.25d | 0d | 1F4CVL | Arch'l |
| 1F5-ARDWG600 |  | P06 - Steel Structure Shop Dwg Approval | 15d | 2018-12-01 | 2018-12-13 | 1F5-ARDWG530, 1F5-ARDWG100, 1F5-ARDWG560 | 73.5d | 6.25d | 1F4CVL | Arch'l |
| 1F5-ARDWG590 |  | P06 - Floors Finishing Shop Dwg Approval | 15d | 2018-12-02 | 2018-12-15 | 1F5-ARDWG580 FF+6.25d, 1F5-ARDWG520, 1F5-ARDWG110 | 5.25d | 0d | 1F4CVL | Arch'l |
| 1F5-ARDWG620 |  | P06 - Doors Shop Drawings Approval | 15d | 2018-12-04 | 2018-12-17 | 1F5-ARDWG590 FF, 1F5-ARDWG570, 1F5-ARDWG130, 1F5-ARDWG550, 1F5-ARDWG560 | 2.75d | 0d | 1F4CVL | Arch'l |
| 1F5-ARDWG610 |  | P06 - Walls Cladding Finishing Shop Dwg Approval | 15d | 2018-12-15 | 2018-12-27 | 1F5-ARDWG120, 1F5-ARDWG570, 1F5-ARDWG540 | 224.75d | 0d | 1F4CVL | Arch'l |

| ID | WBS | Activity | Duration | Start | Finish | Predecessors | Total float | Free float | 1F4 PROJECT | Discipline |
| --- | --- | --- | --- | --- | --- | --- | --- | --- | --- | --- |
|  | 3 | **Mezzanine Level (B05) - Approval of ARCH'L SHOP DWG** |  | 2018-12-18 | 2019-01-17 |  |  |  |  |  |
| 1F5-ARDWG630 |  | B05 - Block Masonry & Plastering Shop Drawings Approval | 15d | 2018-12-18 | 2018-12-31 | 1F5-ARDWG140, 1F5-ARDWG560, 1F5-ARDWG620 | 2.75d | 0d | 1F4CVL | Arch'l |
| 1F5-ARDWG640 |  | B05 - Walls Finishing Shop Drawings Approval | 15d | 2018-12-22 | 2019-01-03 | 1F5-ARDWG150, 1F5-ARDWG630 FF+3.75d | 48.5d | 0d | 1F4CVL | Arch'l |
| 1F5-ARDWG650 |  | B05 - Ceiling Finishing Shop Dwg Approval | 15d | 2018-12-27 | 2019-01-09 | 1F5-ARDWG160, 1F5-ARDWG640 FF+6.25d | 174.75d | 0d | 1F4CVL | Arch'l |
| 1F5-ARDWG670 |  | B05 - Steel Structure Shop Dwg Approval | 15d | 2019-01-01 | 2019-01-14 | 1F5-ARDWG630, 1F5-ARDWG180 | 162.25d | 22.5d | 1F4CVL | Arch'l |
| 1F5-ARDWG660 |  | B05 - Floors Finishing Shop Dwg Approval | 15d | 2019-01-02 | 2019-01-15 | 1F5-ARDWG170, 1F5-ARDWG650 FF+6.25d | 270d | 2.5d | 1F4CVL | Arch'l |
| 1F5-ARDWG680 |  | B05 - Walls Cladding Finishing Shop Dwg Approval | 15d | 2019-01-05 | 2019-01-17 | 1F5-ARDWG640, 1F5-ARDWG190 | 172.25d | 32.5d | 1F4CVL | Arch'l |
| 1F5-ARDWG690 |  | B05 - Doors Shop Dwg Approval | 15d | 2019-01-05 | 2019-01-17 | 1F5-ARDWG640, 1F5-ARDWG200, 1F5-ARDWG660 FF, 1F5-ARDWG630 | 366d | 172.75d | 1F4CVL | Arch'l |
|  | 4 | **Technical Level (B04 ) - Approval of ARCH'L SHOP DWG** |  | 2019-01-01 | 2019-01-31 |  |  |  |  |  |
| 1F5-ARDWG700 |  | B04 - Block Masonry & Plastering Shop Dwg Approval | 15d | 2019-01-01 | 2019-01-14 | 1F5-ARDWG630, 1F5-ARDWG210 | 2.75d | 0d | 1F4CVL | Arch'l |
| 1F5-ARDWG710 |  | B04 -Walls Finishing Shop Dwg Approval | 15d | 2019-01-05 | 2019-01-17 | 1F5-ARDWG700 FF+3.75d, 1F5-ARDWG220 | 171.25d | 0d | 1F4CVL | Arch'l |
| 1F5-ARDWG720 |  | B04 -Ceiling Finishing Shop Dwg Approval | 15d | 2019-01-10 | 2019-01-23 | 1F5-ARDWG710 FF+6.25d, 1F5-ARDWG230 | 281.5d | 0d | 1F4CVL | Arch'l |
| 1F5-ARDWG740 |  | B04 -Steel Structure ShopDwg Approval | 15d | 2019-01-15 | 2019-01-28 | 1F5-ARDWG250, 1F5-ARDWG700 | 161.25d | 55d | 1F4CVL | Arch'l |
| 1F5-ARDWG730 |  | B04 -Floors Finishing Shop Dwg Approval | 15d | 2019-01-16 | 2019-01-29 | 1F5-ARDWG240, 1F5-ARDWG720 FF+6.25d | 353.5d | 2.5d | 1F4CVL | Arch'l |
| 1F5-ARDWG750 |  | B04 -Walls Cladding Finishing Shop Dwg Approval | 15d | 2019-01-19 | 2019-01-31 | 1F5-ARDWG710, 1F5-ARDWG260 | 171.25d | 65d | 1F4CVL | Arch'l |
| 1F5-ARDWG760 |  | B04 -Doors Shop Dwg Approval | 15d | 2019-01-19 | 2019-01-31 | 1F5-ARDWG700, 1F5-ARDWG710, 1F5-ARDWG730 FF, 1F5-ARDWG270 | 351d | 15d | 1F4CVL | Arch'l |
|  | 5 | **Concourse Level (B03) - Approval of ARCH'L SHOP DWG** |  | 2019-01-15 | 2019-02-14 |  |  |  |  |  |
| 1F5-ARDWG770 |  | B03 -Block Masonry & Plastering Shop Dwg Approval | 15d | 2019-01-15 | 2019-01-28 | 1F5-ARDWG280 FF, 1F5-ARDWG280, 1F5-ARDWG700 | 2.75d | 0d | 1F4CVL | Arch'l |
| 1F5-ARDWG780 |  | B03 -Walls Finishing Shop Dwg Approval | 15d | 2019-01-19 | 2019-01-31 | 1F5-ARDWG770 FF+3.75d, 1F5-ARDWG290 | 7.75d | 0d | 1F4CVL | Arch'l |
| 1F5-ARDWG790 |  | B03 -Ceiling Finishing Shop Dwg Approval | 15d | 2019-01-24 | 2019-02-06 | 1F5-ARDWG780 FF+6.25d, 1F5-ARDWG300 | 21.5d | 0d | 1F4CVL | Arch'l |
| 1F5-ARDWG810 |  | B03 -Steel Structure Shop Dwg Approval | 15d | 2019-01-29 | 2019-02-11 | 1F5-ARDWG320, 1F5-ARDWG770 | 9d | 7.5d | 1F4CVL | Arch'l |
| 1F5-ARDWG800 |  | B03 -Floors Finishing Shop Dwg Approval | 15d | 2019-01-30 | 2019-02-12 | 1F5-ARDWG790 FF+6.25d, 1F5-ARDWG310 | 277.5d | 2.5d | 1F4CVL | Arch'l |
| 1F5-ARDWG820 |  | B03 -Walls Cladding Finishing Shop Dwg Approval | 15d | 2019-02-02 | 2019-02-14 | 1F5-ARDWG330, 1F5-ARDWG780 | 19d | 17.5d | 1F4CVL | Arch'l |
| 1F5-ARDWG830 |  | B03 -Doors Shop Dwg Approval | 15d | 2019-02-02 | 2019-02-14 | 1F5-ARDWG800 FF, 1F5-ARDWG770, 1F5-ARDWG780, 1F5-ARDWG340, 1F5-ARDWG760 FF | 336d | 157.75d | 1F4CVL | Arch'l |

| ID | WBS | Activity | Type | Duration | Start | Finish | Predecessors | Total float | Free float | 1F4 PROJECT | Discipline | MSP Activity ID | MEP-Phase |
| --- | --- | --- | --- | --- | --- | --- | --- | --- | --- | --- | --- | --- | --- |
|  | 6 | **TV Louver Level (B02) ) - Approval of ARCH'L SHOP DWG** |  |  | 2019-01-29 | 2019-02-28 |  |  |  |  |  |  |  |
| 1F5-ARDWG840 |  | B02 - Block Masonry & Plastering Shop Dwg Approval |  | 15d | 2019-01-29 | 2019-02-11 | 1F5-ARDWG770, 1F5-ARDWG350 | 52d | 0d | 1F4CVL | Arch'l |  |  |
| 1F5-ARDWG850 |  | B02 - Walls Finishing Shop Dwg Approval |  | 15d | 2019-02-02 | 2019-02-14 | 1F5-ARDWG840 FF+3.75d, 1F5-ARDWG360 | 153.5d | 0d | 1F4CVL | Arch'l |  |  |
| 1F5-ARDWG860 |  | B02 - Ceiling Finishing ShopDwg Approval |  | 15d | 2019-02-07 | 2019-02-20 | 1F5-ARDWG850 FF+6.25d, 1F5-ARDWG370 | 262.5d | 0d | 1F4CVL | Arch'l |  |  |
| 1F5-ARDWG880 |  | B02 - Steel Structure Shop Dwg Approval |  | 15d | 2019-02-12 | 2019-02-25 | 1F5-ARDWG390, 1F5-ARDWG840 | 312.25d | 3.75d | 1F4CVL | Arch'l |  |  |
| 1F5-ARDWG870 |  | B02 - Floors Finishing Shop Dwg Approval |  | 15d | 2019-02-13 | 2019-02-26 | 1F5-ARDWG380, 1F5-ARDWG860 FF+6.25d | 262.5d | 2.5d | 1F4CVL | Arch'l |  |  |
| 1F5-ARDWG890 |  | B02 - Walls Cladding Finishing ShopDwg Approval |  | 15d | 2019-02-16 | 2019-02-28 | 1F5-ARDWG400, 1F5-ARDWG850 | 164.75d | 67.5d | 1F4CVL | Arch'l |  |  |
| 1F5-ARDWG900 |  | B02 - Doors Shop Dwg Approval |  | 15d | 2019-02-16 | 2019-02-28 | 1F5-ARDWG850, 1F5-ARDWG410, 1F5-ARDWG870 FF, 1F5-ARDWG840, 1F5-ARDWG880 FF | 308.5d | 15d | 1F4CVL | Arch'l |  |  |
|  | 7 | **Top Slab Level (B01) - Approval of ARCH'L SHOP DWG** |  |  | 2019-02-12 | 2019-03-14 |  |  |  |  |  |  |  |
| 1F5-ARDWG910 |  | B01 - Block Masonry & Plastering Shop Dwg Approval |  | 15d | 2019-02-12 | 2019-02-25 | 1F5-ARDWG420, 1F5-ARDWG840 | 124.5d | 0d | 1F4CVL | Arch'l |  |  |
| 1F5-ARDWG920 |  | B01 - Walls Finishing Shop Dwg Approval |  | 15d | 2019-02-16 | 2019-02-28 | 1F5-ARDWG910 FF+3.75d, 1F5-ARDWG430 | 129.5d | 0d | 1F4CVL | Arch'l |  |  |
| 1F5-ARDWG930 |  | B01 - Ceiling Finishing Shop DDwg Approval |  | 15d | 2019-02-21 | 2019-03-06 | 1F5-ARDWG920 FF+6.25d, 1F5-ARDWG440 | 143.25d | 0d | 1F4CVL | Arch'l |  |  |
| 1F5-ARDWG950 |  | B01 - Steel Structure Shop Dwg Approval |  | 15d | 2019-02-26 | 2019-03-11 | 1F5-ARDWG460, 1F5-ARDWG910 | 130.75d | 131.25d | 1F4CVL | Arch'l |  |  |
| 1F5-ARDWG940 |  | B01 - Floors Finishing Shop Dwg Approval |  | 15d | 2019-02-27 | 2019-03-12 | 1F5-ARDWG930 FF+6.25d, 1F5-ARDWG450 | 238.5d | 2.5d | 1F4CVL | Arch'l |  |  |
| 1F5-ARDWG960 |  | B01 - Walls Cladding Finishing Shop Dwg Approval |  | 15d | 2019-03-02 | 2019-03-14 | 1F5-ARDWG470, 1F5-ARDWG920 | 140.75d | 141.25d | 1F4CVL | Arch'l |  |  |
| 1F5-ARDWG970 |  | B01 - Doors Shop Dwg Approval |  | 15d | 2019-03-02 | 2019-03-14 | 1F5-ARDWG910, 1F5-ARDWG940 FF, 1F5-ARDWG920, 1F5-ARDWG480, 1F5-ARDWG900 FF | 293.5d | 192.75d | 1F4CVL | Arch'l |  |  |
|  | 1.2 | **MEP ENGINEERING** |  |  | 2018-08-29 | 2019-01-19 |  |  |  |  |  |  |  |
| C1CM11F500100 |  | Receive Information and IFC Drawing from client | milestone | 0d | 2018-08-29 | 2018-08-29 |  | 192.5d | 0d |  |  | 1532 | ENG |
|  | 1.2.1.2.2 | **Shop Drawing Preparation and Submission** |  |  | 2018-08-29 | 2019-01-09 |  |  |  |  |  |  |  |
|  | 1.2.1.2.2.1.2.2.2.1. | **HVAC SYSTEM** |  |  | 2018-10-17 | 2019-01-09 |  |  |  |  |  |  |  |
| C1CM11F500101 |  | Prepare and Submit Combined Service Layout of B07 Under Platform |  | 15d | 2018-10-17 | 2018-10-31 | C1CM11F500100 FS+53d | 350.75d | 0d |  |  | 149 | ENG |
| C1CM11F500102 |  | Prepare and Submit Combined Service Layout of P06 Platform |  | 15d | 2018-10-17 | 2018-10-31 | C1CM11F500100 FS+53d | 350.75d | 0d |  |  | 149 | ENG |
| C1CM11F500103 |  | Prepare and Submit Combined Service Layout of B05 Mezzanine |  | 15d | 2018-10-17 | 2018-10-31 | C1CM11F500100 FS+53d | 350.75d | 0d |  |  | 149 | ENG |
| C1CM11F500110 |  | Prepare and Submit Builders Work Layout for Slab Opening of P06 Platform |  | 10d | 2018-10-22 | 2018-10-31 | C1CM11F500100 FS+58d | 350.75d | 0d |  |  |  | ENG |
| C1CM11F500111 |  | Prepare and Submit Builders Work Layout for Wall Opening of P06 Platform |  | 10d | 2018-10-22 | 2018-10-31 | C1CM11F500100 FS+58d | 350.75d | 0d |  |  |  | ENG |
| C1CM11F500112 |  | Prepare and Submit Builders Work Layout for Slab Opening of B05 Mezzanine |  | 10d | 2018-10-22 | 2018-10-31 | C1CM11F500100 FS+58d | 350.75d | 0d |  |  |  | ENG |
| C1CM11F500113 |  | Prepare and Submit Builders Work Layout for Wall Opening of B05 Mezzanine |  | 10d | 2018-10-22 | 2018-10-31 | C1CM11F500100 FS+58d | 350.75d | 0d |  |  |  | ENG |
| C1CM11F500123 |  | Prepare and Submit shop drawings of P06 Platform |  | 10d | 2018-10-22 | 2018-10-31 | C1CM11F500100 FS+58d | 350.75d | 0d |  |  | 1932 | ENG |
| C1CM11F500124 |  | Prepare and Submit shop drawings of B05 Mezzanine |  | 10d | 2018-10-22 | 2018-10-31 | C1CM11F500100 FS+58d | 350.75d | 0d |  |  | 1932 | ENG |
| C1CM11F500135 |  | Mechanical Ventilation Grille Schedule Sheets 1 to 4 (SG) |  | 6d | 2018-10-25 | 2018-10-31 | C1CM11F500100 FS+62d | 335.75d | 0d |  |  | 148 | ENG |
| C1CM11F500114 |  | Prepare and Submit Builders Work Layout for Slab Opening of B04 Technical |  | 10d | 2018-10-30 | 2018-11-08 | C1CM11F500100 FS+67d | 341.75d | 0d |  |  |  | ENG |
| C1CM11F500115 |  | Prepare and Submit Builders Work Layout for Wall Opening of B04 Technical |  | 10d | 2018-10-30 | 2018-11-08 | C1CM11F500100 FS+67d | 341.75d | 0d |  |  |  | ENG |
| C1CM11F500125 |  | Prepare and Submit shop drawings of B04 Technical |  | 10d | 2018-10-30 | 2018-11-08 | C1CM11F500100 FS+67d | 341.75d | 0d |  |  | 1932 | ENG |
| C1CM11F500134 |  | Mechanical Ventilation Grille Schedule Sheets 1 to 2 (EG & RG) |  | 10d | 2018-10-31 | 2018-11-10 | C1CM11F500100 FS+67d, C1CM11F500135 | 335.75d | 2d |  |  | 148 | ENG |
| C1CM11F500104 |  | Prepare and Submit Combined Service Layout of B04 Technical |  | 15d | 2018-11-03 | 2018-11-15 | C1CM11F500100 FS+70d, C1CM11F500134 SS | 333.75d | 0d |  |  | 149 | ENG |
| C1CM11F500131 |  | Mechanical Specification Sheets 1 to 4 |  | 15d | 2018-11-17 | 2018-11-29 | C1CM11F500100, C1CM11F500129 FF | 323.75d | 1d |  |  | 149 | ENG |
| C1CM11F500108 |  | Prepare and Submit Builders Work Layout for Slab Opening of B07 Under Platform |  | 10d | 2018-11-17 | 2018-11-26 | C1CM11F500100 FS+86d, C1CM11F500131 SS | 322.75d | 0d |  |  |  | ENG |
| C1CM11F500109 |  | Prepare and Submit Builders Work Layout for Wall Opening of B07 Under Platform |  | 10d | 2018-11-17 | 2018-11-26 | C1CM11F500100 FS+86d | 322.75d | 0d |  |  |  | ENG |
| C1CM11F500122 |  | Prepare and Submit shop drawings of B07 Under Platform |  | 10d | 2018-11-17 | 2018-11-26 | C1CM11F500100 FS+86d | 322.75d | 0d |  |  | 1932 | ENG |
| C1CM11F500116 |  | Prepare and Submit Builders Work Layout for Slab Opening of B03 Concourse |  | 10d | 2018-11-21 | 2018-11-29 | C1CM11F500100 FS+90d | 318.75d | 0d |  |  |  | ENG |
| C1CM11F500117 |  | Prepare and Submit Builders Work Layout for Wall Opening of B03 Concourse |  | 10d | 2018-11-21 | 2018-11-29 | C1CM11F500100 FS+90d | 318.75d | 0d |  |  |  | ENG |
| C1CM11F500126 |  | Prepare and Submit shop drawings of B03 Concourse |  | 10d | 2018-11-21 | 2018-11-29 | C1CM11F500100 FS+90d | 318.75d | 0d |  |  | 1932 | ENG |
| C1CM11F500129 |  | Mechanical Notes, Symbols & Abbreviations |  | 6d | 2018-11-25 | 2018-11-29 | C1CM11F500100 FS+94d | 314.75d | 0d |  |  | 147 | ENG |
| C1CM11F500130 |  | Mechanical Standard Details Sheets 1 to 13 |  | 6d | 2018-11-25 | 2018-11-29 | C1CM11F500100, C1CM11F500129 FF, C1CM11F500129 SS | 314.75d | 0d |  |  | 148 | ENG |
| C1CM11F500132 |  | Mechanical Chilled Water Schematic 1 to 3 |  | 6d | 2018-11-25 | 2018-11-29 | C1CM11F500100, C1CM11F500129 FF, C1CM11F500130 SS | 314.75d | 0d |  |  | 148 | ENG |
| C1CM11F500133 |  | Mechanical Ventilation & Smoke Control System Schematic 1 to 13 |  | 6d | 2018-11-25 | 2018-11-29 | C1CM11F500100, C1CM11F500129 FF, C1CM11F500132 SS | 314.75d | 3d |  |  | 148 | ENG |
| C1CM11F500118 |  | Prepare and Submit Builders Work Layout for Slab Opening of B02 Conc Mezz & TV Louvers |  | 10d | 2018-11-27 | 2018-12-06 | C1CM11F500100 FS+97d | 311.75d | 0d |  |  |  | ENG |
| C1CM11F500119 |  | Prepare and Submit Builders Work Layout for Wall Opening of B02 Conc Mezz & TV Louvers |  | 10d | 2018-11-27 | 2018-12-06 | C1CM11F500100 FS+97d | 311.75d | 0d |  |  |  | ENG |
| C1CM11F500127 |  | Prepare and Submit shop drawings of B02 Conc Mezz & TV Louvers |  | 10d | 2018-11-27 | 2018-12-06 | C1CM11F500100 FS+97d, C1CM11F500133 SS | 311.75d | 0d |  |  | 1932 | ENG |
| C1CM11F500105 |  | Prepare and Submit Combined Service Layout of B03 Concourse |  | 15d | 2018-12-01 | 2018-12-13 | C1CM11F500100 FS+100d | 303.75d | 0d |  |  | 149 | ENG |
| C1CM11F500106 |  | Prepare and Submit Combined Service Layout of B02 Conc Mezz & TV Louvers |  | 15d | 2018-12-01 | 2018-12-13 | C1CM11F500100 FS+100d | 303.75d | 0d |  |  | 149 | ENG |
| C1CM11F500107 |  | Prepare and Submit Combined Service Layout of Ground Level G00 |  | 15d | 2018-12-01 | 2018-12-13 | C1CM11F500100 FS+100d | 303.75d | 0d |  |  | 149 | ENG |
| C1CM11F500138 |  | Combined Services Riser 1 to 6 |  | 15d | 2018-12-01 | 2018-12-13 | C1CM11F500100 FS+100d | 308.75d | 12d |  |  | 149 | ENG |
| C1CM11F500121 |  | Prepare and Submit Builders Work Layout for Wall Opening of Ground Level G00 |  | 10d | 2018-12-11 | 2018-12-20 | C1CM11F500100 FS+112d | 296.75d | 0d |  |  |  | ENG |
| C1CM11F500128 |  | Prepare and Submit shop drawings of Ground Level G00 |  | 10d | 2018-12-11 | 2018-12-20 | C1CM11F500100 FS+112d, C1CM11F500138 SS | 296.75d | 0d |  |  | 155 | ENG |
| C1CM11F500136 |  | Combined Services Access & Maintenance Schedule and Notes |  | 15d | 2018-12-17 | 2018-12-31 | C1CM11F500100 FS+118d | 275.75d | 0d |  |  | 149 | ENG |
| C1CM11F500137 |  | Combined Services Typical Sections & Keyplan Sheet 1to 2 |  | 15d | 2018-12-17 | 2018-12-31 | C1CM11F500100, C1CM11F500136 FF | 275.75d | 0d |  |  | 149 | ENG |
| C1CM11F500139 |  | Combined Services Domestic Pump Room - Detail Sheet |  | 15d | 2018-12-17 | 2018-12-31 | C1CM11F500100, C1CM11F500137 FF | 275.75d | 0d |  |  | 149 | ENG |
| C1CM11F500140 |  | Combined Services Fire Pump Room - Detail Sheet |  | 15d | 2018-12-17 | 2018-12-31 | C1CM11F500100, C1CM11F500137 FF, C1CM11F500139 SS | 275.75d | 0d |  |  | 149 | ENG |
| C1CM11F500141 |  | Combined Services CHW Pump Room - Detail Sheet |  | 15d | 2018-12-17 | 2018-12-31 | C1CM11F500100, C1CM11F500137 FF, C1CM11F500140 SS | 275.75d | 0d |  |  | 149 | ENG |
| C1CM11F500120 |  | Prepare and Submit Builders Work Layout for Slab Opening of Ground Level G00 |  | 10d | 2018-12-31 | 2019-01-09 | C1CM11F500100 FS+112d, C1CM11F500141, A1492 | 275.75d | 0d |  |  |  | ENG |

| ID | WBS | Activity | Duration | Start | Finish | Predecessors | Total float | Free float | MSP Activity ID | MEP-Phase |
| --- | --- | --- | --- | --- | --- | --- | --- | --- | --- | --- |
|  | 1.2.1.2.2.1.2.2.2.-1 | **PLUMBING SYSTEM** |  | 2018-10-22 | 2018-12-31 |  |  |  |  |  |
| A1252 |  | Prepare and Submit shop drawings of B05 Mezzanine | 10d | 2018-10-22 | 2018-10-31 | C1CM11F500100 FS+58d | 350.75d | 0d | 1932 | ENG |
| A1292 |  | Prepare and Submit shop drawings of P06 Platform | 10d | 2018-10-22 | 2018-10-31 | C1CM11F500100 FS+58d | 350.75d | 0d | 1932 | ENG |
| A1212 |  | Prepare and Submit shop drawings of B04 Technical | 10d | 2018-10-30 | 2018-11-08 | C1CM11F500100 FS+67d | 341.75d | 0d | 1932 | ENG |
| A1452 |  | Plumbing Notes, Symbols & Abbreviations | 15d | 2018-11-15 | 2018-11-29 | C1CM11F500100 FS+84d | 324.75d | 0d | 149 | ENG |
| A1462 |  | Plumbing Standard Details Public Health Sheet 1 to 5 | 15d | 2018-11-15 | 2018-11-29 | C1CM11F500100 FS+84d, A1452 SS | 324.75d | 0d | 149 | ENG |
| A1472 |  | Plumbing Equipment Schedule Sheet 1 | 15d | 2018-11-15 | 2018-11-29 | C1CM11F500100 FS+84d, A1462 SS | 324.75d | 0d | 149 | ENG |
| A1482 |  | Plumbing Water & Drainage Schematic Sheets 1 to 5 | 15d | 2018-11-15 | 2018-11-29 | C1CM11F500100 FS+84d, A1472 SS | 324.75d | 6d | 149 | ENG |
| A1172 |  | Prepare and Submit shop drawings of B03 Concourse | 10d | 2018-11-21 | 2018-11-29 | C1CM11F500100 FS+90d, A1482 SS | 318.75d | 0d | 1932 | ENG |
| A1332 |  | Prepare and Submit shop drawings of B07 Under Platform | 10d | 2018-11-21 | 2018-11-29 | C1CM11F500100 FS+90d | 318.75d | 0d | 1932 | ENG |
| A1412 |  | Prepare and Submit shop drawings of B02 Conc Mezz & TV Louvers | 10d | 2018-11-27 | 2018-12-06 | C1CM11F500100 FS+97d | 311.75d | 0d | 1932 | ENG |
| A1372 |  | Prepare and Submit shop drawings of Ground Level G00 | 10d | 2018-12-10 | 2018-12-19 | C1CM11F500100 FS+111d | 297.75d | 0d | 155 | ENG |
| A1492 |  | Plumbing Sumps Details Sheets 1 to 3 / Water Services / Egress Stair | 15d | 2018-12-17 | 2018-12-31 | C1CM11F500100 FS+118d | 275.75d | 0d | 149 | ENG |
|  | 1.2.1.2.2.1.2.2.2.-2 | **ELECTRICAL / CONTROLS** |  | 2018-08-29 | 2018-12-09 |  |  |  |  |  |
| A1522 |  | Prepare and Submit shop drawings of Lighting Layout - B05 Mezzanine | 10d | 2018-08-29 | 2018-09-06 | C1CM11F500100 | 398.75d | 0d | 1932 | ENG |
| A1532 |  | Prepare and Submit shop drawings of Lighting Layout - P06 Platform | 10d | 2018-08-29 | 2018-09-06 | C1CM11F500100 | 398.75d | 0d | 1932 | ENG |
| A1542 |  | Prepare and Submit shop drawings of Lighting Layout - B07 Under Platform | 10d | 2018-08-29 | 2018-09-06 | C1CM11F500100 | 398.75d | 0d | 1932 | ENG |
| A1572 |  | Prepare and Submit shop drawings of Small Power Layout - B03 Concourse | 10d | 2018-08-29 | 2018-09-06 | C1CM11F500100 | 398.75d | 0d | 1932 | ENG |
| A1582 |  | Prepare and Submit shop drawings of Small Power Layout - B04 Technical | 10d | 2018-08-29 | 2018-09-06 | C1CM11F500100 | 398.75d | 0d | 1932 | ENG |
| A1592 |  | Prepare and Submit shop drawings of Small Power Layout - B05 Mezzanine | 10d | 2018-08-29 | 2018-09-06 | C1CM11F500100 | 398.75d | 0d | 1932 | ENG |
| A1602 |  | Prepare and Submit shop drawings of Small Power Layout - P06 Platform | 10d | 2018-08-29 | 2018-09-06 | C1CM11F500100 | 398.75d | 0d | 1932 | ENG |
| A1612 |  | Prepare and Submit shop drawings of Small Power Layout - B07 Under Platform | 10d | 2018-08-29 | 2018-09-06 | C1CM11F500100 | 398.75d | 0d | 1932 | ENG |
| A1622 |  | Prepare and Submit shop drawings of Small Power Layout - Ground Level G00 | 10d | 2018-08-29 | 2018-09-06 | C1CM11F500100 | 398.75d | 0d | 155 | ENG |
| A1632 |  | Prepare and Submit shop drawings of Small Power Layout - B02 Conc Mezz & TV Louvers | 10d | 2018-08-29 | 2018-09-06 | C1CM11F500100 | 398.75d | 0d | 1932 | ENG |
| A1642 |  | Prepare and Submit shop drawings of Containment Layout & Sections - B03 Concourse | 10d | 2018-08-29 | 2018-09-06 | C1CM11F500100 | 398.75d | 0d | 1932 | ENG |
| A1652 |  | Prepare and Submit shop drawings of Containment Layout & Sections - B04 Technical | 10d | 2018-08-29 | 2018-09-06 | C1CM11F500100 | 398.75d | 0d | 1932 | ENG |
| A1662 |  | Prepare and Submit shop drawings of Containment Layout & Sections - B05 Mezzanine | 10d | 2018-08-29 | 2018-09-06 | C1CM11F500100 | 398.75d | 0d | 1932 | ENG |
| A1672 |  | Prepare and Submit shop drawings of Containment Layout & Sections - P06 Platform | 10d | 2018-08-29 | 2018-09-06 | C1CM11F500100 | 398.75d | 0d | 1932 | ENG |
| A1682 |  | Prepare and Submit shop drawings of Containment Layout & Sections - B07 Under Platform | 10d | 2018-08-29 | 2018-09-06 | C1CM11F500100 | 398.75d | 0d | 1932 | ENG |
| A1692 |  | Prepare and Submit shop drawings of Containment Layout & Sections - Ground Level G00 | 10d | 2018-08-29 | 2018-09-06 | C1CM11F500100 | 398.75d | 0d | 155 | ENG |
| A1702 |  | Prepare and Submit shop drawings of Containment Layout & Sections - B02 Conc Mezz & TV Louvers | 10d | 2018-08-29 | 2018-09-06 | C1CM11F500100 | 398.75d | 0d | 1932 | ENG |
| A1712 |  | Prepare and Submit shop drawings of Power Layout - B03 Concourse | 10d | 2018-08-29 | 2018-09-06 | C1CM11F500100, A1902 SS | 398.75d | 0d | 1932 | ENG |
| A1722 |  | Prepare and Submit shop drawings of Power Layout - B04 Technical | 10d | 2018-08-29 | 2018-09-06 | C1CM11F500100 | 398.75d | 0d | 1932 | ENG |
| A1732 |  | Prepare and Submit shop drawings of Power Layout - B05 Mezzanine | 10d | 2018-08-29 | 2018-09-06 | C1CM11F500100 | 398.75d | 0d | 1932 | ENG |
| A1742 |  | Prepare and Submit shop drawings of Power Layout - P06 Platform | 10d | 2018-08-29 | 2018-09-06 | C1CM11F500100 | 398.75d | 0d | 1932 | ENG |
| A1752 |  | Prepare and Submit shop drawings of Power Layout - B07 Under Platform | 10d | 2018-08-29 | 2018-09-06 | C1CM11F500100 | 398.75d | 0d | 1932 | ENG |
| A1762 |  | Prepare and Submit shop drawings of Power Layout - Ground Level G00 | 10d | 2018-08-29 | 2018-09-06 | C1CM11F500100 | 398.75d | 0d | 155 | ENG |
| A1772 |  | Prepare and Submit shop drawings of Power Layout - B02 Conc Mezz & TV Louvers | 10d | 2018-08-29 | 2018-09-06 | C1CM11F500100 | 398.75d | 0d | 1932 | ENG |
| A1782 |  | Prepare and Submit shop drawings of Earthing and lightning Protection - B03 Concourse | 10d | 2018-08-29 | 2018-09-06 | C1CM11F500100 | 398.75d | 0d | 1932 | ENG |
| A1792 |  | Prepare and Submit shop drawings of Earthing and lightning Protection - B04 Technical | 10d | 2018-08-29 | 2018-09-06 | C1CM11F500100 | 398.75d | 0d | 1932 | ENG |
| A1802 |  | Prepare and Submit shop drawings of Earthing and lightning Protection - B05 Mezzanine | 10d | 2018-08-29 | 2018-09-06 | C1CM11F500100 | 398.75d | 0d | 1932 | ENG |
| A1812 |  | Prepare and Submit shop drawings of Earthing and lightning Protection - P06 Platform | 10d | 2018-08-29 | 2018-09-06 | C1CM11F500100 | 398.75d | 0d | 1932 | ENG |
| A1822 |  | Prepare and Submit shop drawings of Earthing and lightning Protection - B07 Under Platform | 10d | 2018-08-29 | 2018-09-06 | C1CM11F500100 | 398.75d | 0d | 1932 | ENG |
| A1832 |  | Prepare and Submit shop drawings of Earthing and lightning Protection - Ground Level G00 | 10d | 2018-08-29 | 2018-09-06 | C1CM11F500100 | 398.75d | 0d | 155 | ENG |
| A1842 |  | Prepare and Submit shop drawings of Earthing and lightning Protection - B02 Conc Mezz & TV Louvers | 10d | 2018-08-29 | 2018-09-06 | C1CM11F500100 | 398.75d | 0d | 1932 | ENG |
| A1852 |  | Prepare and Submit Earthing & Bonding Schedule | 10d | 2018-08-29 | 2018-09-06 | C1CM11F500100 | 398.75d | 0d | 1932 | ENG |
| A1862 |  | Prepare and Submit lighting Typical Details Sheet 1 to 3 | 10d | 2018-08-29 | 2018-09-06 | C1CM11F500100, A1852 SS | 398.75d | 0d | 1932 | ENG |
| A1872 |  | Prepare and Submit Electrical Typical Details Sheet 1 to 10 and Cable Tray Typical Details | 10d | 2018-08-29 | 2018-09-06 | C1CM11F500100, A1862 SS | 398.75d | 0d | 1932 | ENG |
| A1882 |  | Prepare and Submit Earthing & Bonding and Protection Typical Details Sheet 1 to 3 | 10d | 2018-08-29 | 2018-09-06 | C1CM11F500100, A1872 SS | 398.75d | 0d | 1932 | ENG |
| A1892 |  | Prepare and Submit MCC schematic and Schedule Sheets | 10d | 2018-08-29 | 2018-09-06 | C1CM11F500100, A1882 SS | 398.75d | 0d | 1932 | ENG |
| A1902 |  | Prepare and Submit Bus Duct System & UPS layout | 10d | 2018-08-29 | 2018-09-06 | C1CM11F500100, A1892 SS | 398.75d | 0d | 1932 | ENG |
| A1512 |  | Prepare and Submit shop drawings of Lighting Layout - B04 Technical | 10d | 2018-10-24 | 2018-11-01 | C1CM11F500100 FS+60d | 338.75d | 0d | 1932 | ENG |
| A1502 |  | Prepare and Submit shop drawings of Lighting Layout - B03 Concourse | 10d | 2018-11-13 | 2018-11-22 | C1CM11F500100 FS+82d | 316.75d | 0d | 1932 | ENG |
| A1562 |  | Prepare and Submit shop drawings of Lighting Layout - B02 Conc Mezz & TV Louvers | 10d | 2018-11-21 | 2018-11-29 | C1CM11F500100 FS+90d | 308.75d | 0d | 1932 | ENG |
| A1552 |  | Prepare and Submit shop drawings of Lighting Layout - Ground Level G00 | 10d | 2018-12-01 | 2018-12-09 | C1CM11F500100 FS+100d | 308.75d | 0d | 155 | ENG |

| ID | WBS | Activity | Duration | Start | Finish | Predecessors | Total float | Free float | MSP Activity ID | MEP-Phase |
| --- | --- | --- | --- | --- | --- | --- | --- | --- | --- | --- |
|  | 1.2.1.2.2.1.2.2.2.-3 | **FIRE FIGHTING SYSTEM** |  | 2018-08-29 | 2018-09-11 |  |  |  |  |  |
| A1912 |  | Prepare and Submit shop drawings of B03 Concourse | 10d | 2018-08-29 | 2018-09-06 | C1CM11F500100 | 192.5d | 0d | 1932 | ENG |
| A1922 |  | Prepare and Submit shop drawings of B04 Technical | 10d | 2018-08-29 | 2018-09-06 | C1CM11F500100 | 192.5d | 0d | 1932 | ENG |
| A1932 |  | Prepare and Submit shop drawings of B05 Mezzanine | 10d | 2018-08-29 | 2018-09-06 | C1CM11F500100 | 192.5d | 0d | 1932 | ENG |
| A1942 |  | Prepare and Submit shop drawings of P06 Platform | 10d | 2018-08-29 | 2018-09-06 | C1CM11F500100 | 192.5d | 0d | 1932 | ENG |
| A1952 |  | Prepare and Submit shop drawings of B07 Under Platform | 10d | 2018-08-29 | 2018-09-06 | C1CM11F500100 | 192.5d | 0d | 1932 | ENG |
| A1962 |  | Prepare and Submit shop drawings of Ground Level G00 | 10d | 2018-08-29 | 2018-09-06 | C1CM11F500100, A2002 SS | 192.5d | 0d | 155 | ENG |
| A1972 |  | Prepare and Submit shop drawings of B02 Conc Mezz & TV Louvers | 10d | 2018-08-29 | 2018-09-06 | C1CM11F500100 | 192.5d | 0d | 1932 | ENG |
| A1982 |  | Fire Protection Notes, Symbols & Abbreviations | 15d | 2018-08-29 | 2018-09-11 | C1CM11F500100 | 192.5d | 0d | 149 | ENG |
| A1992 |  | Fire Protection Standard Details Sheet 1 to 4 | 15d | 2018-08-29 | 2018-09-11 | C1CM11F500100, A1982 SS | 192.5d | 0d | 149 | ENG |
| A2002 |  | Fire Services Schematic Sheet 1 to 3 | 15d | 2018-08-29 | 2018-09-11 | C1CM11F500100, A1992 SS | 192.5d | 0d | 149 | ENG |
|  | 1 | **Shop Drawing Review and Approval** |  | 2018-09-08 | 2019-01-19 |  |  |  |  |  |
|  | 1.2.1.2.2.1.2.2.2.1. | **HVAC SYSTEM** |  | 2018-10-31 | 2019-01-19 |  |  |  |  |  |
| A2092 |  | Reveiw and Approval shop drawings of B05 Mezzanine | 10d | 2018-10-31 | 2018-11-10 | C1CM11F500124 | 350.75d | 32d | 1932 | ENG |
| A2102 |  | Reveiw and Approval Builders Work Layout for Wall Opening of B05 Mezzanine | 10d | 2018-10-31 | 2018-11-10 | C1CM11F500113, A2132 SS | 350.75d | 0d |  | ENG |
| A2112 |  | Reveiw and Approval Builders Work Layout for Slab Opening of B05 Mezzanine | 10d | 2018-10-31 | 2018-11-10 | C1CM11F500112, A2102 SS | 350.75d | 0d |  | ENG |
| A2122 |  | Reveiw and Approval Combined Service Layout of B05 Mezzanine | 15d | 2018-10-31 | 2018-11-14 | C1CM11F500103, A2162 SS | 350.75d | 9d | 149 | ENG |
| A2132 |  | Reveiw and Approval shop drawings of P06 Platform | 10d | 2018-10-31 | 2018-11-10 | C1CM11F500123 | 350.75d | 0d | 1932 | ENG |
| A2142 |  | Reveiw and Approval Builders Work Layout for Wall Opening of P06 Platform | 10d | 2018-10-31 | 2018-11-10 | C1CM11F500111, A2112 SS | 350.75d | 0d |  | ENG |
| A2152 |  | Reveiw and Approval Builders Work Layout for Slab Opening of P06 Platform | 10d | 2018-10-31 | 2018-11-10 | C1CM11F500110, A2142 SS | 350.75d | 0d |  | ENG |
| A2162 |  | Reveiw and Approval Combined Service Layout of P06 Platform | 15d | 2018-10-31 | 2018-11-14 | C1CM11F500102, A2202 SS | 350.75d | 0d | 149 | ENG |
| A2202 |  | Reveiw and Approval Combined Service Layout of B07 Under Platform | 15d | 2018-10-31 | 2018-11-14 | C1CM11F500101, A2152 SS | 350.75d | 0d | 149 | ENG |
| A2052 |  | Reveiw and Approval Shop drawings of B04 Technical | 10d | 2018-11-08 | 2018-11-18 | C1CM11F500125, A2122 SS | 341.75d | 0d | 1932 | ENG |
| A2062 |  | Reveiw and Approval Builders Work Layout for Wall Opening of B04 Technical | 10d | 2018-11-08 | 2018-11-18 | C1CM11F500115, A2052 SS | 341.75d | 0d |  | ENG |
| A2072 |  | Reveiw and Approval Builders Work Layout for Slab Opening of B04 Technical | 10d | 2018-11-08 | 2018-11-18 | C1CM11F500114, A2062 SS | 341.75d | 8d |  | ENG |
| A2082 |  | Reveiw and Approval Combined Service Layout of B04 Technical | 15d | 2018-11-17 | 2018-11-29 | C1CM11F500104, A2072 SS | 333.75d | 11d | 149 | ENG |
| A2172 |  | Reveiw and Approval shop drawings of B07 Under Platform | 10d | 2018-11-26 | 2018-12-05 | C1CM11F500122, A2082 SS | 322.75d | 0d | 1932 | ENG |
| A2182 |  | Reveiw and Approval Builders Work Layout for Wall Opening of B07 Under Platform | 10d | 2018-11-26 | 2018-12-05 | C1CM11F500109, A2172 SS | 322.75d | 0d |  | ENG |
| A2192 |  | Reveiw and Approval Builders Work Layout for Slab Opening of B07 Under Platform | 10d | 2018-11-26 | 2018-12-05 | C1CM11F500108, A2182 SS | 322.75d | 4d |  | ENG |
| A2012 |  | Reveiw and Approval shop drawings of B03 Concourse | 10d | 2018-12-01 | 2018-12-09 | C1CM11F500126, A2192 SS | 318.75d | 0d | 1932 | ENG |
| A2022 |  | Reveiw and Approval Builders Work Layout for Wall Opening of B03 Concourse | 10d | 2018-12-01 | 2018-12-09 | C1CM11F500117, A2012 SS | 318.75d | 0d |  | ENG |
| A2032 |  | Reveiw and Approval Builders Work Layout for Slab Opening of B03 Concourse | 10d | 2018-12-01 | 2018-12-09 | C1CM11F500116, A2092 SS, A2022 SS | 318.75d | 7d |  | ENG |
| A2252 |  | Reveiw and Approval shop drawings of B02 Conc Mezz & TV Louvers | 10d | 2018-12-06 | 2018-12-16 | C1CM11F500127, A2272 SS | 311.75d | 8d | 1932 | ENG |
| A2262 |  | Reveiw and Approval Builders Work Layout for Wall Opening of B02 Conc Mezz & TV Louvers | 10d | 2018-12-06 | 2018-12-16 | C1CM11F500119, A2032 SS | 311.75d | 0d |  | ENG |
| A2272 |  | Reveiw and Approval Builders Work Layout for Slab Opening of B02 Conc Mezz & TV Louvers | 10d | 2018-12-06 | 2018-12-16 | C1CM11F500118, A2262 SS | 311.75d | 0d |  | ENG |
| A2042 |  | Reveiw and Approval Combined Service Layout of B03 Concourse | 15d | 2018-12-15 | 2018-12-27 | C1CM11F500105, A2242 SS | 303.75d | 7d | 149 | ENG |
| A2242 |  | Reveiw and Approval Combined Service Layout of Ground Level G00 | 15d | 2018-12-15 | 2018-12-27 | C1CM11F500107, A2282 SS | 303.75d | 0d | 149 | ENG |
| A2282 |  | Reveiw and Approval Combined Service Layout of B02 Conc Mezz & TV Louvers | 15d | 2018-12-15 | 2018-12-27 | C1CM11F500106, A2252 SS | 303.75d | 0d | 149 | ENG |
| A2212 |  | Reveiw and Approval shop drawings of Ground Level G00 | 10d | 2018-12-20 | 2018-12-30 | C1CM11F500128, A2042 SS | 296.75d | 0d | 155 | ENG |
| A2222 |  | Reveiw and Approval Builders Work Layout for Wall Opening of Ground Level G00 | 10d | 2018-12-20 | 2018-12-30 | C1CM11F500121, A2212 SS, A2342 SS | 296.75d | 21d |  | ENG |
| A2232 |  | Reveiw and Approval Builders Work Layout for Slab Opening of Ground Level G00 | 10d | 2019-01-09 | 2019-01-19 | C1CM11F500120, A2222 SS | 275.75d | 10.25d |  | ENG |

| ID | WBS | Activity | Duration | Start | Finish | Predecessors | Total float | Free float | MSP Activity ID | MEP-Phase |
| --- | --- | --- | --- | --- | --- | --- | --- | --- | --- | --- |
|  | 1.2.1.2.2.1.2.2.2.-1 | **PLUMBING SYSTEM** |  | 2018-10-31 | 2018-12-29 |  |  |  |  |  |
| A2312 |  | Reveiw and Approval shop drawings of B05 Mezzanine | 10d | 2018-10-31 | 2018-11-10 | A1252 | 350.75d | 0d | 1932 | ENG |
| A2322 |  | Reveiw and Approval shop drawings of P06 Platform | 10d | 2018-10-31 | 2018-11-10 | A1292, A2312 SS | 350.75d | 9d | 1932 | ENG |
| A2302 |  | Reveiw and Approval shop drawings of B04 Technical | 10d | 2018-11-08 | 2018-11-18 | A1212, A2322 SS | 341.75d | 23d | 1932 | ENG |
| A2292 |  | Reveiw and Approval shop drawings of B03 Concourse | 10d | 2018-12-01 | 2018-12-09 | A1172, A2302 SS | 318.75d | 0d | 1932 | ENG |
| A2332 |  | Reveiw and Approval shop drawings of B07 Under Platform | 10d | 2018-12-01 | 2018-12-09 | A1332, A2292 SS | 318.75d | 7d | 1932 | ENG |
| A2352 |  | Reveiw and Approval shop drawings of B02 Conc Mezz & TV Louvers | 10d | 2018-12-06 | 2018-12-16 | A1412, A2332 SS | 311.75d | 14d | 1932 | ENG |
| A2342 |  | Reveiw and Approval shop drawings of Ground Level G00 | 10d | 2018-12-19 | 2018-12-29 | A1372, A2352 SS, A2412 SS | 297.75d | 1d | 155 | ENG |
|  | 1.2.1.2.2.1.2.2.2.-2 | **ELECTRICAL / CONTROLS** |  | 2018-09-08 | 2018-12-18 |  |  |  |  |  |
| A2382 |  | Reveiw and Approval shop drawings of Lighting Layout - B05 Mezzanine | 10d | 2018-09-08 | 2018-09-16 | A1522 | 398.75d | 0d | 1932 | ENG |
| A2392 |  | Reveiw and Approval shop drawings of Lighting Layout - P06 Platform | 10d | 2018-09-08 | 2018-09-16 | A1532, A2382 SS | 398.75d | 0d | 1932 | ENG |
| A2402 |  | Reveiw and Approval shop drawings of Lighting Layout - B07 Under Platform | 10d | 2018-09-08 | 2018-09-16 | A1542, A2392 SS | 398.75d | 0d | 1932 | ENG |
| A2432 |  | Reveiw and Approval shop drawings of Small Power Layout - B03 Concourse | 10d | 2018-09-08 | 2018-09-16 | A1572, A2492 SS | 398.75d | 0d | 1932 | ENG |
| A2442 |  | Reveiw and Approval shop drawings of Small Power Layout - B04 Technical | 10d | 2018-09-08 | 2018-09-16 | A1582, A2432 SS | 398.75d | 0d | 1932 | ENG |
| A2452 |  | Reveiw and Approval shop drawings of Small Power Layout - B05 Mezzanine | 10d | 2018-09-08 | 2018-09-16 | A1592, A2442 SS | 398.75d | 0d | 1932 | ENG |
| A2462 |  | Reveiw and Approval shop drawings of Small Power Layout - P06 Platform | 10d | 2018-09-08 | 2018-09-16 | A1602, A2452 SS | 398.75d | 0d | 1932 | ENG |
| A2472 |  | Reveiw and Approval shop drawings of Small Power Layout - B07 Under Platform | 10d | 2018-09-08 | 2018-09-16 | A1612, A2462 SS | 398.75d | 0d | 1932 | ENG |
| A2482 |  | Reveiw and Approval Shop drawings of Small Power Layout - Ground Level G00 | 10d | 2018-09-08 | 2018-09-16 | A1622, A2402 SS | 398.75d | 0d | 155 | ENG |
| A2492 |  | Reveiw and Approval shop drawings of Small Power Layout - B02 Conc Mezz & TV Louvers | 10d | 2018-09-08 | 2018-09-16 | A1632, A2482 SS | 398.75d | 0d | 1932 | ENG |
| A2502 |  | Reveiw and Approval shop drawings of Containment Layout & Sections - B03 Concourse | 10d | 2018-09-08 | 2018-09-16 | A1642, A2562 SS | 398.75d | 0d | 1932 | ENG |
| A2512 |  | Reveiw and Approval shop drawings of Containment Layout & Sections - B04 Technical | 10d | 2018-09-08 | 2018-09-16 | A1652, A2502 SS | 398.75d | 0d | 1932 | ENG |
| A2522 |  | Reveiw and Approval shop drawings of Containment Layout & Sections - B05 Mezzanine | 10d | 2018-09-08 | 2018-09-16 | A1662, A2512 SS | 398.75d | 0d | 1932 | ENG |
| A2532 |  | Reveiw and Approval shop drawings of Containment Layout & Sections - P06 Platform | 10d | 2018-09-08 | 2018-09-16 | A1672, A2522 SS | 398.75d | 0d | 1932 | ENG |
| A2542 |  | Reveiw and Approval shop drawings of Containment Layout & Sections - B07 Under Platform | 10d | 2018-09-08 | 2018-09-16 | A1682, A2532 SS | 398.75d | 0d | 1932 | ENG |
| A2552 |  | Reveiw and Approval shop drawings of Containment Layout & Sections - Ground Level G00 | 10d | 2018-09-08 | 2018-09-16 | A1692, A2472 SS | 398.75d | 0d | 155 | ENG |
| A2562 |  | Reveiw and Approval shop drawings of Containment Layout & Sections - B02 Conc Mezz & TV Louvers | 10d | 2018-09-08 | 2018-09-16 | A1702, A2552 SS | 398.75d | 0d | 1932 | ENG |
| A2572 |  | Reveiw and Approval shop drawings of Power Layout - B03 Concourse | 10d | 2018-09-08 | 2018-09-16 | A1712, A2632 SS | 398.75d | 0d | 1932 | ENG |
| A2582 |  | Reveiw and Approval shop drawings of Power Layout - B04 Technical | 10d | 2018-09-08 | 2018-09-16 | A1722, A2572 SS | 398.75d | 0d | 1932 | ENG |
| A2592 |  | Reveiw and Approval shop drawings of Power Layout - B05 Mezzanine | 10d | 2018-09-08 | 2018-09-16 | A1732, A2582 SS | 398.75d | 0d | 1932 | ENG |
| A2602 |  | Reveiw and Approval shop drawings of Power Layout - P06 Platform | 10d | 2018-09-08 | 2018-09-16 | A1742, A2592 SS | 398.75d | 0d | 1932 | ENG |
| A2612 |  | Reveiw and Approval shop drawings of Power Layout - B07 Under Platform | 10d | 2018-09-08 | 2018-09-16 | A1752, A2602 SS | 398.75d | 0d | 1932 | ENG |
| A2622 |  | Reveiw and Approval shop drawings of Power Layout - Ground Level G00 | 10d | 2018-09-08 | 2018-09-16 | A1762, A2542 SS | 398.75d | 0d | 155 | ENG |
| A2632 |  | Reveiw and Approval shop drawings of Power Layout - B02 Conc Mezz & TV Louvers | 10d | 2018-09-08 | 2018-09-16 | A1772, A2622 SS | 398.75d | 0d | 1932 | ENG |
| A2642 |  | Reveiw and Approval shop drawings of Earthing and lightning Protection - B03 Concourse | 10d | 2018-09-08 | 2018-09-16 | A1782, A2702 SS | 398.75d | 0d | 1932 | ENG |
| A2652 |  | Reveiw and Approval shop drawings of Earthing and lightning Protection - B04 Technical | 10d | 2018-09-08 | 2018-09-16 | A1792, A2642 SS | 398.75d | 0d | 1932 | ENG |
| A2662 |  | Reveiw and Approval shop drawings of Earthing and lightning Protection - B05 Mezzanine | 10d | 2018-09-08 | 2018-09-16 | A1802, A2652 SS | 398.75d | 0d | 1932 | ENG |
| A2672 |  | Reveiw and Approval shop drawings of Earthing and lightning Protection - P06 Platform | 10d | 2018-09-08 | 2018-09-16 | A1812, A2662 SS | 398.75d | 0d | 1932 | ENG |
| A2682 |  | Reveiw and Approval shop drawings of Earthing and lightning Protection - B07 Under Platform | 10d | 2018-09-08 | 2018-09-16 | A1822, A2672 SS | 398.75d | 60d | 1932 | ENG |
| A2692 |  | Reveiw and Approval shop drawings of Earthing and lightning Protection - Ground Level G00 | 10d | 2018-09-08 | 2018-09-16 | A1832, A2612 SS | 398.75d | 0d | 155 | ENG |
| A2702 |  | Reveiw and Approval shop drawings of Earthing and lightning Protection - B02 Conc Mezz & TV Louvers | 10d | 2018-09-08 | 2018-09-16 | A1842, A2692 SS | 398.75d | 0d | 1932 | ENG |
| A2372 |  | Reveiw and Approval shop drawings of Lighting Layout - B04 Technical | 10d | 2018-11-03 | 2018-11-11 | A1512, A2682 SS | 338.75d | 22d | 1932 | ENG |
| A2362 |  | Reveiw and Approval shop drawings of Lighting Layout - B03 Concourse | 10d | 2018-11-22 | 2018-12-02 | A1502, A2372 SS | 316.75d | 8d | 1932 | ENG |
| A2422 |  | Reveiw and Approval shop drawings of Lighting Layout - B02 Conc Mezz & TV Louvers | 10d | 2018-12-01 | 2018-12-09 | A1562, A2362 SS | 308.75d | 0d | 1932 | ENG |
| A2412 |  | Reveiw and Approval shop drawings of Lighting Layout - Ground Level G00 | 10d | 2018-12-10 | 2018-12-18 | A1552, A2422 | 308.75d | 11d | 155 | ENG |

| ID | WBS | Activity | Duration | Start | Finish | Predecessors | Total float | Free float | MSP Activity ID | MEP-Phase |
| --- | --- | --- | --- | --- | --- | --- | --- | --- | --- | --- |
|  | 1.2.1.2.2.1.2.2.2.-3 | **FIRE FIGHTING SYSTEM** |  | 2018-09-08 | 2018-09-16 |  |  |  |  |  |
| A2712 |  | Reveiw and Approval shop drawings of B03 Concourse | 10d | 2018-09-08 | 2018-09-16 | A1912, A2772 SS | 192.5d | 0d | 1932 | ENG |
| A2722 |  | Reveiw and Approval shop drawings of B04 Technical | 10d | 2018-09-08 | 2018-09-16 | A1922, A2712 SS | 192.5d | 0d | 1932 | ENG |
| A2732 |  | Reveiw and Approval shop drawings of B05 Mezzanine | 10d | 2018-09-08 | 2018-09-16 | A1932, A2722 SS | 192.5d | 0d | 1932 | ENG |
| A2742 |  | Reveiw and Approval shop drawings of P06 Platform | 10d | 2018-09-08 | 2018-09-16 | A1942, A2732 SS | 192.5d | 0d | 1932 | ENG |
| A2752 |  | Reveiw and Approval shop drawings of B07 Under Platform | 10d | 2018-09-08 | 2018-09-16 | A1952, A2742 SS | 192.5d | 0d | 1932 | ENG |
| A2762 |  | Reveiw and Approval shop drawings of Ground Level G00 | 10d | 2018-09-08 | 2018-09-16 | A1962, A2752 FF | 192.5d | 156.25d | 155 | ENG |
| A2772 |  | Reveiw and Approval shop drawings of B02 Conc Mezz & TV Louvers | 10d | 2018-09-08 | 2018-09-16 | A1972 | 192.5d | 0d | 1932 | ENG |
|  | 1.2.1.2.1 | **MAR Production and Submission** |  | 2018-08-29 | 2018-08-29 |  |  |  |  |  |
|  | 1.2.2.1 | **HVAC** |  | 2018-08-29 | 2018-08-29 |  |  |  |  |  |
| RMLE2C100052 |  | Prepare and Submit Document for GI Metal Duct | 1d | 2018-08-29 | 2018-08-29 | C1CM11F500100 | 436.62d | 0d | 77 | ENG |
| RMLE2C100053 |  | Prepare and Submit Document for Duct Insulation (Al. Jacket, Foil and Paper Jacket) | 1d | 2018-08-29 | 2018-08-29 | C1CM11F500100 | 438.62d | 2d | 79 | ENG |
| RMLE2C100054 |  | Prepare and Submit Document for Bulk Materials (Duct / Piping Hangers & Supports and Accessories) | 1d | 2018-08-29 | 2018-08-29 | C1CM11F500100 | 437.62d | 0d | 74 | ENG |
| RMLE2C100055 |  | Prepare and Submit Document for Expansion Joints | 1d | 2018-08-29 | 2018-08-29 | C1CM11F500100 | 439.62d | 3d | 2200 | ENG |
| RMLE2C100056 |  | Prepare and Submit Document for Valves and Ancillaries (Gate Valves, Check Valve, Inspection Test & Drain Valve) | 1d | 2018-08-29 | 2018-08-29 | C1CM11F500100 | 449.62d | 13d | 2214 | ENG |
| RMLE2C100057 |  | Prepare and Submit Document for Flexible Pipe Connector | 1d | 2018-08-29 | 2018-08-29 | C1CM11F500100 | 440.62d | 4d | 2198 | ENG |
| RMLE2C100058 |  | Prepare and Submit Document for Di-Electric Unions & Flangs | 1d | 2018-08-29 | 2018-08-29 | C1CM11F500100 | 441.62d | 5d | 2197 | ENG |
| RMLE2C100059 |  | Prepare and Submit Document for Fiber Glass Duct Insulation (Flexible Elastometric) | 1d | 2018-08-29 | 2018-08-29 | C1CM11F500100 | 442.62d | 6d | 2202 | ENG |
| RMLE2C100060 |  | Prepare and Submit Document for Ref. Piping (Copper Tube) | 1d | 2018-08-29 | 2018-08-29 | C1CM11F500100 | 443.62d | 7d | 91 | ENG |
| RMLE2C100061 |  | Prepare and Submit Document for Copper Pipes & Fittings for Water Distribution copper Brazing Filler / Adhensive Flux | 1d | 2018-08-29 | 2018-08-29 | C1CM11F500100 | 444.62d | 8d | 2205 | ENG |
| RMLE2C100062 |  | Prepare and Submit document for Flexible Duct and Accessories (VD, MVD, BDD, FD, MSD,MFSD) | 1d | 2018-08-29 | 2018-08-29 | C1CM11F500100 | 445.62d | 9d | 2207 | ENG |
| RMLE2C100063 |  | Prepare and Submit Document for Air Curtains and Air Ionization Units | 1d | 2018-08-29 | 2018-08-29 | C1CM11F500100 | 450.62d | 14d | 2212 | ENG |
| RMLE2C100064 |  | Prepare and Submit Material Submittal for Air Handling Units (AHU, ACCU, CRAC, FCU, VRV and SPLIT AC) | 1d | 2018-08-29 | 2018-08-29 | C1CM11F500100 | 446.62d | 10d | 41 | ENG |
| RMLE2C100065 |  | Prepare and Submit Material Submittal for HVAC Fans | 1d | 2018-08-29 | 2018-08-29 | C1CM11F500100 | 447.62d | 11d | 49 | ENG |
| RMLE2C100066 |  | Prepare and Submit Document for SS Metal Duct | 1d | 2018-08-29 | 2018-08-29 | C1CM11F500100 | 437.62d | 1d | 2195 | ENG |
| RMLE2C100067 |  | Prepare and Submit Document for Vibration Isolators | 1d | 2018-08-29 | 2018-08-29 | C1CM11F500100 | 448.62d | 12d | 2216 | ENG |
| RMLE2C100068 |  | Prepare and Submit Material submittal for Meters And Gauges | 1d | 2018-08-29 | 2018-08-29 | C1CM11F500100 | 451.62d | 15d | 31 | ENG |
| RMLE2C100069 |  | Prepare and Submit Document for Airoutlets (Grilles, Diffures etc...) | 1d | 2018-08-29 | 2018-08-29 | C1CM11F500100 | 452.62d | 16d | 126 | ENG |

| ID | WBS | Activity | Duration | Start | Finish | Predecessors | Total float | Free float | MSP Activity ID | MEP-Phase |
| --- | --- | --- | --- | --- | --- | --- | --- | --- | --- | --- |
|  | 1.2.2.2 | **PLUMBING** |  | 2018-08-29 | 2018-08-29 |  |  |  |  |  |
| RMLE2C100070 |  | Prepare and Submit Document for Trap Primet Valve (Mechanical Type) | 1d | 2018-08-29 | 2018-08-29 | C1CM11F500100 | 450.62d | 5d | 2220 | ENG |
| RMLE2C100071 |  | Prepare and Submit Documet for GRP Water Storage Tanks Assy. | 1d | 2018-08-29 | 2018-08-29 | C1CM11F500100 | 451.62d | 6d | 2226 | ENG |
| RMLE2C100072 |  | Prepare and submit documents for PVC Pipes & Fittings (Condensate Drain Pipes & Fittings Underground Piping)/Solvent Cem | 1d | 2018-08-29 | 2018-08-29 | C1CM11F500100 | 448.62d | 3d | 2218 | ENG |
| RMLE2C100073 |  | Prepare and Submit document for Electric Water heaters | 1d | 2018-08-29 | 2018-08-29 | C1CM11F500100 | 452.62d | 7d | 99 | ENG |
| RMLE2C100074 |  | Prepare and Submit Document for Back Flow Preventer/ Water Hammer Arrestor/ Trap Seal Device/ Trap Primer Valve / Hose B | 1d | 2018-08-29 | 2018-08-29 | C1CM11F500100 | 453.62d | 17d | 101 | ENG |
| RMLE2C100075 |  | Prepare and Submit Document for Plumbing Fixtures | 1d | 2018-08-29 | 2018-08-29 | C1CM11F500100 | 445.62d | 0d | 116 | ENG |
| RMLE2C100076 |  | Prepare and Submit Document for Ductile Iron Pipes & Fittings for Drainage & Vent Piping | 1d | 2018-08-29 | 2018-08-29 | C1CM11F500100 | 446.62d | 1d | 93 | ENG |
| RMLE2C100077 |  | Prepare and submit documents for Cast Iron Pipes & Fittings for Drainage & Vent Piping | 1d | 2018-08-29 | 2018-08-29 | C1CM11F500100 | 447.62d | 2d | 97 | ENG |
| RMLE2C100078 |  | Prepare and Submit Material Submittal for Oil Interceptor | 1d | 2018-08-29 | 2018-08-29 | C1CM11F500100 | 454.62d | 18d | 118 | ENG |
| RMLE2C100079 |  | Prepare and Submit Material submittal for Water Meter | 1d | 2018-08-29 | 2018-08-29 | C1CM11F500100 | 455.62d | 19d | 120 | ENG |
| RMLE2C100080 |  | Prepare and Submit Document for Floor Drains / Floor Cleanouts / Vent Cowl | 1d | 2018-08-29 | 2018-08-29 | C1CM11F500100 | 449.62d | 4d | 2222 | ENG |
|  | 1.2.2.3 | **ELECTRICAL** |  | 2018-08-29 | 2018-08-29 |  |  |  |  |  |
| RMLE2C100081 |  | Prepare and submit Material submittal for Electrical Panels (MCC'S, Switch Boards and Panel Boards) | 1d | 2018-08-29 | 2018-08-29 | C1CM11F500100 | 466.62d | 30d | 55 | ENG |
| RMLE2C100082 |  | Prepare and Submit Document for Flexiable Metal Conduit and Fittings | 1d | 2018-08-29 | 2018-08-29 | C1CM11F500100 | 461.62d | 25d | 2232 | ENG |
| RMLE2C100083 |  | Prepare and Submit Document for Liquid Tight Flexiable Conduit | 1d | 2018-08-29 | 2018-08-29 | C1CM11F500100 | 462.62d | 26d | 2238 | ENG |
| RMLE2C100084 |  | Prepare and Submit Document for Containment (Cable Tray, Cable Trunking a | 1d | 2018-08-29 | 2018-08-29 | C1CM11F500100 | 463.62d | 27d | 2242 | ENG |
| RMLE2C100085 |  | Prepare and Submit Document for Supports System (Threaded Rod, Unistrut, Channels, Ancchor Bolts, Etcï¿½) | 1d | 2018-08-29 | 2018-08-29 | C1CM11F500100 | 464.62d | 28d | 2240 | ENG |
| RMLE2C100086 |  | Prepare & Submit Material Submittal for Grounding and Lighting Protection System | 1d | 2018-08-29 | 2018-08-29 | C1CM11F500100 | 465.62d | 29d | 69 | ENG |
| RMLE2C100087 |  | Prepare & Submit Material Submittal for Access control System (Door locks Only) and Fire Stop System | 1d | 2018-08-29 | 2018-08-29 | C1CM11F500100 | 473.62d | 37d | 71 | ENG |
| RMLE2C100088 |  | Prepare & Submit Material Submittal for Lighting Control System and Devices | 1d | 2018-08-29 | 2018-08-29 | C1CM11F500100 | 469.62d | 33d | 67 | ENG |
| RMLE2C100089 |  | Prepare and submit Material submittal for Power Factor Correction System | 1d | 2018-08-29 | 2018-08-29 | C1CM11F500100 | 470.62d | 34d | 61 | ENG |
| RMLE2C100090 |  | Prepare & Submit Material Submittal for Central Battery System | 1d | 2018-08-29 | 2018-08-29 | C1CM11F500100 | 471.62d | 35d | 65 | ENG |
| RMLE2C100091 |  | Prepare & Submit Document for Lighting Fixtures (Interior & Exterior) | 1d | 2018-08-29 | 2018-08-29 | C1CM11F500100 | 474.62d | 38d | 130 | ENG |
| RMLE2C100092 |  | Prepare & Submit Material Submittal for Low Current Cables and Control Cables | 1d | 2018-08-29 | 2018-08-29 | C1CM11F500100 | 472.62d | 36d | 2244 | ENG |
| RMLE2C100093 |  | Prepare and Submit Document for RSC and PVC Conduit and Fittings | 1d | 2018-08-29 | 2018-08-29 | C1CM11F500100 | 459.62d | 23d | 2236 | ENG |
| RMLE2C100094 |  | Prepare and submit Material submittal for Cooper Bus Duct System | 1d | 2018-08-29 | 2018-08-29 | C1CM11F500100 | 467.62d | 31d | 57 | ENG |
| RMLE2C100095 |  | Prepare and Submit Document for EMT Conduits and Fittings | 1d | 2018-08-29 | 2018-08-29 | C1CM11F500100 | 456.62d | 20d | 109 | ENG |
| RMLE2C100096 |  | Prepare and Submit Document for LV Cables and Wires | 1d | 2018-08-29 | 2018-08-29 | C1CM11F500100 | 457.62d | 21d | 2230 | ENG |
| RMLE2C100097 |  | Prepare and Submit Document for Glands, Lugs and Ties | 1d | 2018-08-29 | 2018-08-29 | C1CM11F500100 | 458.62d | 22d | 2228 | ENG |
| RMLE2C100098 |  | Prepare and Submit Document for Juntion Boxes | 1d | 2018-08-29 | 2018-08-29 | C1CM11F500100 | 460.62d | 24d | 2234 | ENG |
| RMLE2C100099 |  | Prepare & Submit Document for Wiring and Devices Accessories | 1d | 2018-08-29 | 2018-08-29 | C1CM11F500100 | 468.62d | 32d | 132 | ENG |

| ID | WBS | Activity | Duration | Start | Finish | Predecessors | Total float | Free float | MSP Activity ID | MEP-Phase |
| --- | --- | --- | --- | --- | --- | --- | --- | --- | --- | --- |
|  | 1.2.2.4 | **FIRE FIGHTING** |  | 2018-08-29 | 2018-08-29 |  |  |  |  |  |
| RMLE2C100100 |  | Prepare and submit Document for Grooved Fittings | 1d | 2018-08-29 | 2018-08-29 | C1CM11F500100 | 475.62d | 39d | 2251 | ENG |
| RMLE2C100101 |  | Prepare and submit Document for FF Hangers and supports | 1d | 2018-08-29 | 2018-08-29 | C1CM11F500100 | 476.62d | 40d | 2249 | ENG |
| RMLE2C100102 |  | Prepare and submit Document for Carbon Steel Pipe Grooved & Thredad | 1d | 2018-08-29 | 2018-08-29 | C1CM11F500100 | 477.62d | 41d | 2247 | ENG |
| RMLE2C100103 |  | Prepare and submit Document for Valves and Ancillaries (Gate Valves, Check Valve, Inspection Test & Drain Valve) | 1d | 2018-08-29 | 2018-08-29 | C1CM11F500100 | 478.62d | 42d | 105 | ENG |
| RMLE2C100104 |  | Prepare and submit Document for Fire Department Connection | 1d | 2018-08-29 | 2018-08-29 | C1CM11F500100 | 484.62d | 48d | 103 | ENG |
| RMLE2C100105 |  | Prepare and submit Document for Treaded Fittings | 1d | 2018-08-29 | 2018-08-29 | C1CM11F500100 | 479.62d | 43d | 2253 | ENG |
| RMLE2C100106 |  | Prepare and submit Document for Paint For Fire Pipes | 1d | 2018-08-29 | 2018-08-29 | C1CM11F500100 | 480.62d | 44d | 2257 | ENG |
| RMLE2C100107 |  | Prepare and submit Document for Fire Hose Cabinet | 1d | 2018-08-29 | 2018-08-29 | C1CM11F500100 | 481.62d | 45d | 2255 | ENG |
| RMLE2C100108 |  | Prepare and submit Document for Fire Extinguisher C02 & ABC | 1d | 2018-08-29 | 2018-08-29 | C1CM11F500100 | 482.62d | 46d | 2259 | ENG |
| RMLE2C100109 |  | Prepare & Submit Material submittal for Fire Suppression Sprinkler (Pendant, Sidewall and Upright Sprinklers) | 1d | 2018-08-29 | 2018-08-29 | C1CM11F500100 | 483.62d | 47d | 107 | ENG |
| RMLE2C100110 |  | Prepare and submit Document for Street Pillar Hydrant & Tank Fill connector | 1d | 2018-08-29 | 2018-08-29 | C1CM11F500100 | 485.62d | 49d | 2262 | ENG |
|  | 2 | **MAR Review and Approval** |  | 2018-08-29 | 2018-10-15 |  |  |  |  |  |
|  | 1 | **HVAC** |  | 2018-08-29 | 2018-09-15 |  |  |  |  |  |
| RMLE2C100111 |  | Approval for GI Metal Duct | 1d | 2018-08-29 | 2018-08-30 | RMLE2C100052 | 436.62d | 0d | 78 | ENG |
| RMLE2C100113 |  | Approval for Bulk Materials (Duct / Piping Hangers & Supports and Accessories) | 1d | 2018-08-29 | 2018-08-30 | RMLE2C100054 | 437.62d | 1d | 75 | ENG |
| RMLE2C100125 |  | Approval for SS Metal Duct | 1d | 2018-08-30 | 2018-09-01 | RMLE2C100066, RMLE2C100111 | 436.62d | 0d | 2194 | ENG |
| RMLE2C100112 |  | Approval for Submitted Document for Duct Insulation (Al. Jacket, Foil and Paper Jacket) | 1d | 2018-09-01 | 2018-09-02 | RMLE2C100053, RMLE2C100125, RMLE2C100113 | 436.62d | 0d | 80 | ENG |
| RMLE2C100114 |  | Approval for Submitted Document for Expansion Joints | 1d | 2018-09-02 | 2018-09-02 | RMLE2C100055, RMLE2C100112 | 436.62d | 0d | 2199 | ENG |
| RMLE2C100116 |  | Approval for Submitted Document for Flexible Pipe Connector | 1d | 2018-09-03 | 2018-09-03 | RMLE2C100057, RMLE2C100114 | 436.62d | 0d | 2201 | ENG |
| RMLE2C100117 |  | Approval for Submitted Document for Di-Electric Unions & Flangs | 1d | 2018-09-03 | 2018-09-04 | RMLE2C100058, RMLE2C100116 | 436.62d | 0d | 2203 | ENG |
| RMLE2C100118 |  | Approval for Submitted Document for Fiber Glass Duct Insulation (Flexible Elastometric) | 1d | 2018-09-04 | 2018-09-05 | RMLE2C100059, RMLE2C100117 | 436.62d | 0d | 2196 | ENG |
| RMLE2C100119 |  | Approval for Ref. Piping (Copper Tube) | 1d | 2018-09-05 | 2018-09-06 | RMLE2C100060, RMLE2C100118 | 436.62d | 0d | 92 | ENG |
| RMLE2C100120 |  | Approval for Copper Pipes & Fittings for Water Distribution copper Brazing Filler / Adhensive Flux | 1d | 2018-09-06 | 2018-09-06 | RMLE2C100061, RMLE2C100119 | 436.62d | 0d | 2204 | ENG |
| RMLE2C100121 |  | Approval for Flexible Duct and Accessories (VD, MVD, BDD, FD, MSD,MFSD) | 1d | 2018-09-08 | 2018-09-08 | RMLE2C100062, RMLE2C100120 | 436.62d | 0d | 2206 | ENG |
| RMLE2C100123 |  | Approval for material submittal of Air Handling Units (AHU, ACCU, CRAC, FCU,VRV and SPLIT AC) | 1d | 2018-09-08 | 2018-09-09 | RMLE2C100064, RMLE2C100121 | 436.62d | 0d | 42 | ENG |
| RMLE2C100124 |  | Approval for material submittal of HVAC Fans | 1d | 2018-09-09 | 2018-09-10 | RMLE2C100065, RMLE2C100123 | 436.62d | 0d | 50 | ENG |
| RMLE2C100126 |  | Approval for Vibration Isolators | 1d | 2018-09-10 | 2018-09-11 | RMLE2C100067, RMLE2C100124 | 436.62d | 0d | 2215 | ENG |
| RMLE2C100115 |  | Approval for Valves and Ancillaries (Gate Valves, Check Valve, Inspection Test & Drain Valve) | 1d | 2018-09-11 | 2018-09-11 | RMLE2C100056, RMLE2C100126 | 436.62d | 0d | 2213 | ENG |
| RMLE2C100122 |  | Approval for Air Curtains and Air Ionization Units | 1d | 2018-09-12 | 2018-09-12 | RMLE2C100063, RMLE2C100115 | 436.62d | 0d | 2211 | ENG |
| RMLE2C100127 |  | Approval for Material Submittal of Meters And Gauges | 1d | 2018-09-12 | 2018-09-13 | RMLE2C100068, RMLE2C100122 | 436.62d | 0d | 32 | ENG |
| RMLE2C100128 |  | Approval of Submitted Document for (Grilles, Diffures etcï¿½) | 1d | 2018-09-13 | 2018-09-15 | RMLE2C100069, RMLE2C100127 | 436.62d | 0d | 127 | ENG |

| ID | WBS | Activity | Duration | Start | Finish | Predecessors | Total float | Free float | MSP Activity ID | MEP-Phase |
| --- | --- | --- | --- | --- | --- | --- | --- | --- | --- | --- |
|  | 4 | **PLUMBING** |  | 2018-08-29 | 2018-09-17 |  |  |  |  |  |
| RMLE2C100132 |  | Approval for Plumbing Fixtures | 1d | 2018-08-29 | 2018-08-30 | RMLE2C100075 | 445.62d | 0d | 117 | ENG |
| RMLE2C100133 |  | Approval for Ductile Iron Pipes & Fittings for Drainage & Vent Piping | 1d | 2018-08-30 | 2018-09-01 | RMLE2C100076, RMLE2C100132 | 445.62d | 0d | 94 | ENG |
| RMLE2C100134 |  | Approval of submitted document for Cast Iron Pipes & Fittings for Drainage & Vent Piping | 1d | 2018-09-01 | 2018-09-02 | RMLE2C100077, RMLE2C100133 | 445.62d | 0d | 98 | ENG |
| RMLE2C100136 |  | Approval for PVC Pipes & Fittings (Condensate Drain Pipes & Fittings Underground Piping)/Solvent Cement | 1d | 2018-09-02 | 2018-09-02 | RMLE2C100072, RMLE2C100134 | 445.62d | 0d | 2217 | ENG |
| RMLE2C100137 |  | Approval for Floor Drains / Floor Cleanouts / Vent Cowl | 1d | 2018-09-03 | 2018-09-03 | RMLE2C100080, RMLE2C100136 | 445.62d | 0d | 2221 | ENG |
| RMLE2C100138 |  | Approval for Trap Primet Valve (Mechanical Type) | 1d | 2018-09-03 | 2018-09-04 | RMLE2C100070, RMLE2C100137 | 445.62d | 0d | 2219 | ENG |
| RMLE2C100139 |  | Approval for GRP Water Storage Tanks Assy. | 1d | 2018-09-04 | 2018-09-05 | RMLE2C100071, RMLE2C100138 | 445.62d | 0d | 2225 | ENG |
| RMLE2C100135 |  | Approval of document for Electric Water Heaters | 1d | 2018-09-05 | 2018-09-06 | RMLE2C100073, RMLE2C100139 | 445.62d | 9d | 100 | ENG |
| RMLE2C100129 |  | Approval of Back Flow Preventer/ Water Hammer Arrestor/ Trap Seal Device/ Trap Primer Valve / Hose Bib | 1d | 2018-09-15 | 2018-09-16 | RMLE2C100074, RMLE2C100128, RMLE2C100135 | 436.62d | 0d | 102 | ENG |
| RMLE2C100130 |  | Approval of material submittal for Oil Interceptor | 1d | 2018-09-16 | 2018-09-16 | RMLE2C100078, RMLE2C100129 | 436.62d | 0d | 119 | ENG |
| RMLE2C100131 |  | Approval of material Submittal of Water Meter | 1d | 2018-09-17 | 2018-09-17 | RMLE2C100079, RMLE2C100130 | 436.62d | 0d | 121 | ENG |
|  | 2 | **ELECTRICAL** |  | 2018-09-17 | 2018-10-04 |  |  |  |  |  |
| RMLE2C100147 |  | Approval for EMT Conduits and Fittings | 1d | 2018-09-17 | 2018-09-18 | RMLE2C100095, RMLE2C100131 | 436.62d | 0d | 110 | ENG |
| RMLE2C100148 |  | Approval for LV Cables and Wires | 1d | 2018-09-18 | 2018-09-19 | RMLE2C100096, RMLE2C100147 | 436.62d | 0d | 2229 | ENG |
| RMLE2C100149 |  | Approval for Glands, Lugs and Ties | 1d | 2018-09-19 | 2018-09-20 | RMLE2C100097, RMLE2C100148 | 436.62d | 0d | 2227 | ENG |
| RMLE2C100150 |  | Approval for RSC and PVC Conduit and Fittings | 1d | 2018-09-20 | 2018-09-20 | RMLE2C100093, RMLE2C100149 | 436.62d | 0d | 2235 | ENG |
| RMLE2C100151 |  | Approval for Junction Boxes | 1d | 2018-09-22 | 2018-09-22 | RMLE2C100098, RMLE2C100150 | 436.62d | 0d | 2233 | ENG |
| RMLE2C100152 |  | Approval for Flexiable Metal Conduit and Fittings | 1d | 2018-09-22 | 2018-09-23 | RMLE2C100082, RMLE2C100151 | 436.62d | 0d | 2231 | ENG |
| RMLE2C100153 |  | Approval for Liquid Tight Flexible Conduit | 1d | 2018-09-23 | 2018-09-24 | RMLE2C100083, RMLE2C100152 | 436.62d | 0d | 2237 | ENG |
| RMLE2C100154 |  | Approval for Containment (Cable Tray, Cable Trunking and Cable Ladder) | 1d | 2018-09-24 | 2018-09-25 | RMLE2C100084, RMLE2C100153 | 436.62d | 0d | 2241 | ENG |
| RMLE2C100155 |  | Approval for Supports System (Threaded Rod, Unistrut, Channels, Ancchor Bolts, Etcï¿½) | 1d | 2018-09-25 | 2018-09-25 | RMLE2C100085, RMLE2C100154 | 436.62d | 0d | 2239 | ENG |
| RMLE2C100156 |  | Approval of Material Submittal for Grounding and Lighting Protection System | 1d | 2018-09-26 | 2018-09-26 | RMLE2C100086, RMLE2C100155 | 436.62d | 0d | 70 | ENG |
| RMLE2C100142 |  | Approval of Material Submittal of Electrical Panels (MCC'S, Switch Boards and Panel Boards) | 1d | 2018-09-26 | 2018-09-27 | RMLE2C100081, RMLE2C100156 | 436.62d | 0d | 56 | ENG |
| RMLE2C100143 |  | Approval of Material Submittal of Cooper Bus Duct System | 1d | 2018-09-27 | 2018-09-29 | RMLE2C100094, RMLE2C100142 | 436.62d | 0d | 58 | ENG |
| RMLE2C100145 |  | Approval of Document for Wiring and Devices Accessories | 1d | 2018-09-29 | 2018-09-30 | RMLE2C100099, RMLE2C100143 | 436.62d | 0d | 133 | ENG |
| RMLE2C100157 |  | Approval of Material Submittal for Lighting Control System and Devices | 1d | 2018-09-30 | 2018-09-30 | RMLE2C100088, RMLE2C100145 | 436.62d | 0d | 68 | ENG |
| RMLE2C100144 |  | Approval of Material Submittal of Power Factor Correction System | 1d | 2018-10-01 | 2018-10-01 | RMLE2C100089, RMLE2C100157 | 436.62d | 0d | 62 | ENG |
| RMLE2C100140 |  | Approval of Material Submittal for Central Battery System | 1d | 2018-10-01 | 2018-10-02 | RMLE2C100090, RMLE2C100144 | 436.62d | 0d | 66 | ENG |
| RMLE2C100158 |  | Approval of Material Submittal for Low Current Cables and Control Cables | 1d | 2018-10-02 | 2018-10-03 | RMLE2C100092, RMLE2C100140 | 436.62d | 0d | 2243 | ENG |
| RMLE2C100141 |  | Approval of Material Submittal for Access control System (Door locks Only) and Fire Stop System | 1d | 2018-10-03 | 2018-10-04 | RMLE2C100087, RMLE2C100158 | 436.62d | 0d | 72 | ENG |
| RMLE2C100146 |  | Approval of Document for Lighting Fixtures (Interior & Exterior) | 1d | 2018-10-04 | 2018-10-04 | RMLE2C100091, RMLE2C100141 | 436.62d | 0d | 131 | ENG |

| ID | WBS | Activity | Duration | Start | Finish | Predecessors | Total float | Free float | Constraint | MSP Activity ID | MEP-Phase | 1F4 PROJECT | Discipline |
| --- | --- | --- | --- | --- | --- | --- | --- | --- | --- | --- | --- | --- | --- |
|  | 3 | **FIRE FIGHTING** |  | 2018-10-06 | 2018-10-15 |  |  |  |  |  |  |  |  |
| RMLE2C100165 |  | Approval for submitted Document of Grooved Fittings | 1d | 2018-10-06 | 2018-10-06 | RMLE2C100100, RMLE2C100146, RMLE2C100100 FF | 436.62d | 0d |  | 2250 | ENG |  |  |
| RMLE2C100166 |  | Approval for submitted Document of FF Hangers and supports | 1d | 2018-10-06 | 2018-10-07 | RMLE2C100101, RMLE2C100165 | 436.62d | 0d |  | 2248 | ENG |  |  |
| RMLE2C100167 |  | Approval for submitted Document of Carbon Steel Pipe Grooved & Thredad | 1d | 2018-10-07 | 2018-10-08 | RMLE2C100102, RMLE2C100166 | 436.62d | 0d |  | 2246 | ENG |  |  |
| RMLE2C100164 |  | Approval for document of Valves and Ancillaries (Gate Valves, Check Valve, Inspection Test & Drain Valve) | 1d | 2018-10-08 | 2018-10-09 | RMLE2C100103, RMLE2C100167 | 436.62d | 0d |  | 106 | ENG |  |  |
| RMLE2C100168 |  | Approval for document of Treaded Fittings | 1d | 2018-10-09 | 2018-10-09 | RMLE2C100105, RMLE2C100164 | 436.62d | 0d |  | 2252 | ENG |  |  |
| RMLE2C100169 |  | Approval for document of Paint For Fire Pipes | 1d | 2018-10-10 | 2018-10-10 | RMLE2C100106, RMLE2C100168 | 436.62d | 0d |  | 2256 | ENG |  |  |
| RMLE2C100159 |  | Approval for document of Fire Hose Cabinet | 1d | 2018-10-10 | 2018-10-11 | RMLE2C100107, RMLE2C100169 | 436.62d | 0d |  | 2254 | ENG |  |  |
| RMLE2C100161 |  | Approval for document of Fire Extinguisher C02 & ABC | 1d | 2018-10-11 | 2018-10-13 | RMLE2C100108, RMLE2C100159 | 436.62d | 0d |  | 2258 | ENG |  |  |
| RMLE2C100162 |  | Approval for document of Fire Suppression Sprinkler (Pendant Sprinkler, Sidewall Sprinkler and Upright Sprinkler) | 1d | 2018-10-13 | 2018-10-14 | RMLE2C100109, RMLE2C100161 | 436.62d | 0d |  | 108 | ENG |  |  |
| RMLE2C100163 |  | Approval for submitted Document of Fire Department Connection | 1d | 2018-10-14 | 2018-10-14 | RMLE2C100104, RMLE2C100162 | 436.62d | 0d |  | 104 | ENG |  |  |
| RMLE2C100160 |  | Approval for submitted Document of Street Pillar Hydrant & Tank Fill connector | 1d | 2018-10-15 | 2018-10-15 | RMLE2C100110, RMLE2C100163 | 436.62d | 0d |  | 2261 | ENG |  |  |
|  | 4 | **PROCUREMENTS** |  | 2018-08-30 | 2019-04-11 |  |  |  |  |  |  |  |  |
|  | 5 | **ARCHITECTURAL & CIVIL PROCUREMENT** |  | 2018-11-01 | 2019-04-11 |  |  |  |  |  |  |  |  |
|  | 1 | **MATERIAL SUBMITTAL** |  | 2018-11-01 | 2018-12-23 |  |  |  |  |  |  |  |  |
| 1F5-PRO-GN-010 |  | PSD Steel Structure Submittals | 18.75d | 2018-11-01 | 2018-11-18 | B150, MOB1F5030 | 23.5d | 0d | start on or after 2018-11-01 |  |  | 1F4CVL | Civil |
| 1F5-PRO-GN-030 |  | Plasterboard Ceiling Submittals | 18.75d | 2018-11-01 | 2018-11-18 | 1F5-PRO-GN-010 SS | 23.5d | 0d |  |  |  | 1F4CVL | Arch'l |
| 1F5-PRO-GN-050 |  | Granite & Marble tiles Submittals | 18.75d | 2018-11-01 | 2018-11-18 | 1F5-PRO-GN-030 SS | 41.25d | 0d |  |  |  | 1F4CVL | Arch'l |
| 1F5-PRO-GN-090 |  | Raised Floor Submittals | 18.75d | 2018-11-01 | 2018-11-18 | 1F5-PRO-GN-100 SS | 41.25d | 0d |  |  |  | 1F4CVL | Arch'l |
| 1F5-PRO-GN-100 |  | ESD rubber flooring Submittals | 18.75d | 2018-11-01 | 2018-11-18 | 1F5-PRO-GN-050 SS | 41.25d | 0d |  |  |  | 1F4CVL | Arch'l |
| 1F5-PRO-GN-020 |  | Structural Steel Submittals | 18.75d | 2018-11-19 | 2018-12-05 | 1F5-PRO-GN-010 | 73.5d | 0d |  |  |  | 1F4CVL | Civil |
| 1F5-PRO-GN-060 |  | Porcelain Tile Submittals | 18.75d | 2018-11-19 | 2018-12-05 | 1F5-PRO-GN-030 | 45d | 0d |  |  |  | 1F4CVL | Arch'l |
| 1F5-PRO-GN-080 |  | Metal Ceiling Submittals | 18.75d | 2018-11-19 | 2018-12-05 | 1F5-PRO-GN-010 | 41.25d | 0d |  |  |  | 1F4CVL | Arch'l |
| 1F5-PRO-GN-110 |  | Metal Doors & Louvres Submittals | 18.75d | 2018-11-19 | 2018-12-05 | 1F5-PRO-GN-090 | 41.25d | 0d |  |  |  | 1F4CVL | Arch'l |
| 1F5-PRO-GN-120 |  | Hardwares Submittals | 18.75d | 2018-11-19 | 2018-12-05 | 1F5-PRO-GN-110 SS | 41.25d | 0d |  |  |  | 1F4CVL | Arch'l |
| 1F5-PRO-GN-130 |  | Way Finding Signage Submittals | 18.75d | 2018-11-19 | 2018-12-05 | 1F5-PRO-GN-120 FF | 243.75d | 0d |  |  |  | 1F4CVL | Arch'l |
| 1F5-PRO-GN-040 |  | Glazed doors Submittals | 18.75d | 2018-12-06 | 2018-12-23 | 1F5-PRO-GN-060 | 45d | 0d |  |  |  | 1F4CVL | Arch'l |
| 1F5-PRO-GN-070 |  | Acoustic Panels Walls/Ceiling Submittals | 18.75d | 2018-12-06 | 2018-12-23 | 1F5-PRO-GN-080 | 45d | 0d |  |  |  | 1F4CVL | Arch'l |

| ID | WBS | Activity | Duration | Start | Finish | Predecessors | Total float | Free float | 1F4 PROJECT | Discipline |
| --- | --- | --- | --- | --- | --- | --- | --- | --- | --- | --- |
|  | 2 | **MATERIAL APPROVAL** |  | 2018-11-19 | 2019-01-09 |  |  |  |  |  |
| 1F5-PRO-GN-210 |  | PSD Steel Structure Approval | 18.75d | 2018-11-19 | 2018-12-05 | 1F5-PRO-GN-010 | 41.25d | 0d | 1F4CVL |  |
| 1F5-PRO-GN-230 |  | Plasterboard Ceiling Approval | 18.75d | 2018-11-19 | 2018-12-05 | 1F5-PRO-GN-030 | 23.5d | 0d | 1F4CVL |  |
| 1F5-PRO-GN-250 |  | Granite & Marble tiles Approval | 18.75d | 2018-11-19 | 2018-12-05 | 1F5-PRO-GN-050 | 247.5d | 10d | 1F4CVL |  |
| 1F5-PRO-GN-290 |  | Raised Floor Approval | 18.75d | 2018-11-19 | 2018-12-05 | 1F5-PRO-GN-300 SS, 1F5-PRO-GN-090 | 41.25d | 0d | 1F4CVL |  |
| 1F5-PRO-GN-300 |  | ESD rubber flooring Approval | 18.75d | 2018-11-19 | 2018-12-05 | 1F5-PRO-GN-100 | 41.25d | 0d | 1F4CVL |  |
| 1F5-PRO-GN-220 |  | Structural Steel Approval | 18.75d | 2018-12-06 | 2018-12-23 | 1F5-PRO-GN-020, 1F5-PRO-GN-210 | 73.5d | 0d | 1F4CVL |  |
| 1F5-PRO-GN-260 |  | Porcelain Tile Approval | 18.75d | 2018-12-06 | 2018-12-23 | 1F5-PRO-GN-060, 1F5-PRO-GN-230 | 45d | 0d | 1F4CVL |  |
| 1F5-PRO-GN-280 |  | Metal Ceiling Approval | 18.75d | 2018-12-06 | 2018-12-23 | 1F5-PRO-GN-210, 1F5-PRO-GN-080 | 41.25d | 0d | 1F4CVL |  |
| 1F5-PRO-GN-310 |  | Metal Doors & Louvres Approval | 18.75d | 2018-12-06 | 2018-12-23 | 1F5-PRO-GN-110, 1F5-PRO-GN-290 | 41.25d | 0d | 1F4CVL |  |
| 1F5-PRO-GN-320 |  | Hardwares Approval | 18.75d | 2018-12-06 | 2018-12-23 | 1F5-PRO-GN-310 SS, 1F5-PRO-GN-120 | 41.25d | 0d | 1F4CVL |  |
| 1F5-PRO-GN-330 |  | Way Finding Signage Approval | 18.75d | 2018-12-06 | 2018-12-23 | 1F5-PRO-GN-130, 1F5-PRO-GN-320 FF | 243.75d | 5d | 1F4CVL |  |
| 1F5-PRO-GN-240 |  | Glazed doors Approval | 18.75d | 2018-12-24 | 2019-01-09 | 1F5-PRO-GN-040, 1F5-PRO-GN-260 | 45d | 0d | 1F4CVL |  |
| 1F5-PRO-GN-270 |  | Acoustic Panels Walls/Ceiling Approval | 18.75d | 2018-12-24 | 2019-01-09 | 1F5-PRO-GN-280, 1F5-PRO-GN-070 | 45d | 0d | 1F4CVL |  |
|  | 3 | **MATERIAL MANUFACTURE & DELIVERY** |  | 2018-12-06 | 2019-04-11 |  |  |  |  |  |
| 1F5-PRO-GN-410 |  | PSD Steel Structure Manufacture & Delivery | 75d | 2018-12-06 | 2019-02-13 | 1F5-PRO-GN-210, 1F5-ARDWG600 SS | 67.25d | 40d | 1F4CVL | Civil |
| 1F5-PRO-GN-430 |  | Plasterboard Ceiling Manufacture & Delivery | 90d | 2018-12-10 | 2019-03-03 | 1F5-PRO-GN-230, 1F5-ARDWG580 | 19.75d | 18.75d | 1F4CVL | Arch'l |
| 1F5-PRO-GN-450 |  | Granite & Marble tiles Manufacture & Delivery | 112.5d | 2018-12-16 | 2019-03-30 | 1F5-PRO-GN-250, 1F5-ARDWG110, 1F5-ARDWG590 | 237.5d | 8.75d | 1F4CVL | Arch'l |
| 1F5-PRO-GN-490 |  | Raised Floor Manufacture & Delivery | 112.5d | 2018-12-16 | 2019-03-30 | 1F5-PRO-GN-290, 1F5-ARDWG590 SS, 1F5-ARDWG590 | 204.75d | 0d | 1F4CVL | Arch'l |
| 1F5-PRO-GN-500 |  | ESD rubber flooring Manufacture & Delivery | 112.5d | 2018-12-16 | 2019-03-30 | 1F5-PRO-GN-300, 1F5-ARDWG110, 1F5-ARDWG590 | 237.5d | 13.75d | 1F4CVL | Arch'l |
| 1F5-PRO-GN-420 |  | Structural Steel Manufacture & Delivery | 90d | 2018-12-24 | 2019-03-17 | 1F5-PRO-GN-220, 1F5-ARDWG100, 1F5-ARDWG600 | 73.5d | 46.25d | 1F4CVL | Civil |
| 1F5-PRO-GN-460 |  | Porcelain Tile Manufacture & Delivery | 112.5d | 2018-12-24 | 2019-04-07 | 1F5-PRO-GN-260, 1F5-PRO-GN-450 SS, 1F5-ARDWG590 | 228.75d | 5d | 1F4CVL | Arch'l |
| 1F5-PRO-GN-480 |  | Metal Ceiling Manufacture & Delivery | 112.5d | 2018-12-24 | 2019-04-07 | 1F5-PRO-GN-280, 1F5-PRO-GN-440 FF, 1F5-PRO-GN-470 FF, 1F5-ARDWG580 | 41.25d | 0d | 1F4CVL | Arch'l |
| 1F5-PRO-GN-510 |  | Metal Doors & Louvres Manufacture & Delivery | 112.5d | 2018-12-24 | 2019-04-07 | 1F5-PRO-GN-310, 1F5-PRO-GN-480 FF, 1F5-ARDWG620 | 41.25d | 40.25d | 1F4CVL | Arch'l |
| 1F5-PRO-GN-520 |  | Hardwares Manufacture & Delivery | 112.5d | 2018-12-24 | 2019-04-07 | 1F5-PRO-GN-320, 1F5-ARDWG620 | 41.25d | 40.25d | 1F4CVL | Arch'l |
| 1F5-PRO-GN-530 |  | Way Finding Signage Manufacture & Delivery | 112.5d | 2018-12-29 | 2019-04-11 | 1F5-PRO-GN-330, 1F5-PRO-GN-460 SS, 1F5-PRO-GN-500 SS, 1F5-ARDWG610 | 238.75d | 121.5d | 1F4CVL | Arch'l |
| 1F5-PRO-GN-440 |  | Glazed doors Manufacture & Delivery | 90d | 2019-01-10 | 2019-04-03 | 1F5-PRO-GN-240, 1F5-ARDWG130, 1F5-ARDWG620 | 45d | 3.75d | 1F4CVL | Arch'l |
| 1F5-PRO-GN-470 |  | Acoustic Panels Walls/Ceiling Manufacture & Delivery | 90d | 2019-01-10 | 2019-04-03 | 1F5-PRO-GN-270, 1F5-ARDWG090, 1F5-ARDWG580, 1F5-ARDWG570 | 45d | 0d | 1F4CVL | Arch'l |

| ID | WBS | Activity | Duration | Start | Finish | Predecessors | Total float | Free float | MEP-Phase | MSP Activity ID |
| --- | --- | --- | --- | --- | --- | --- | --- | --- | --- | --- |
|  | 1.3 | **MEP PROCUREMENT** |  | 2018-08-30 | 2019-02-13 |  |  |  |  |  |
|  | 1 | **RFQ and PO Issuance** |  | 2018-08-30 | 2018-11-03 |  |  |  |  |  |
|  | 1 | **LONG LEAD ITEMS** |  | 2018-09-09 | 2018-11-03 |  |  |  |  |  |
|  | 1 | **HVAC SYSTEM** |  | 2018-10-24 | 2018-11-03 |  |  |  |  |  |
| RMLP2C100001 |  | PO Issuance Process for Air Curtains & Air Ionization Units | 10d | 2018-10-24 | 2018-11-03 | RMLP2C100007 | 483.62d | 0d | PRC |  |
| RMLP2C100002 |  | PO Issuance Process for AHU | 10d | 2018-10-24 | 2018-11-03 | RMLP2C100003 SS | 483.62d | 0d | PRC | 2175 |
| RMLP2C100003 |  | PO Issuance Process for ACCU | 10d | 2018-10-24 | 2018-11-03 | RMLP2C100004 SS | 483.62d | 0d | PRC | 2176 |
| RMLP2C100004 |  | PO Issuance Process for CRAC Units | 10d | 2018-10-24 | 2018-11-03 | RMLP2C100005 SS | 483.62d | 0d | PRC | 2177 |
| RMLP2C100005 |  | PO Issuance Process for Fan Coil Units | 10d | 2018-10-24 | 2018-11-03 | RMLP2C100006 SS | 483.62d | 0d | PRC | 2178 |
| RMLP2C100006 |  | PO Issuance Process for Exhaust Fans | 10d | 2018-10-24 | 2018-11-03 | RMLP2C100001 SS | 483.62d | 0d | PRC | 2179 |
|  | 4 | **PLUMBING SYSTEM** |  | 2018-10-15 | 2018-10-24 |  |  |  |  |  |
| RMLP2C100007 |  | PO Issuance Process for Tank Circulation Pump | 10d | 2018-10-15 | 2018-10-24 | RMLP2C100008 SS | 483.62d | 0d | PRC | 2185 |
| RMLP2C100008 |  | PO Issuance Process for GRP Water Storage Tank | 10d | 2018-10-15 | 2018-10-24 | RMLP2C100009 SS | 483.62d | 0d | PRC | 2184 |
| RMLP2C100009 |  | PO Issuance Process for Water treatment Plant | 10d | 2018-10-15 | 2018-10-24 | RMLP2C100010 SS | 483.62d | 0d | PRC | 2186 |
| RMLP2C100010 |  | PO Issuance Process for Plumbing Fixtures | 10d | 2018-10-15 | 2018-10-24 | RMLP2C100013 SS | 483.62d | 0d | PRC | 2187 |
|  | 3 | **ELECTRICAL / CONTROLS** |  | 2018-10-15 | 2018-10-24 |  |  |  |  |  |
| RMLP2C100011 |  | PO Issuance Process for Central Battery System | 10d | 2018-10-15 | 2018-10-24 | RMLP2C100012 SS | 478.62d | 0d | PRC |  |
| RMLP2C100012 |  | PO Issuance Process for Access control System (Door locks Only) | 10d | 2018-10-15 | 2018-10-24 | RMLP2C100023 SS | 478.62d | 0d | PRC |  |
| RMLP2C100013 |  | PO Issuance Process for MCC'S, Switch Boards and Panel Boards | 10d | 2018-10-15 | 2018-10-24 | RMLP2C100014 SS | 478.62d | 0d | PRC | 2188 |
| RMLP2C100014 |  | PO Issuance Process for Cooper Bus Duct System | 10d | 2018-10-15 | 2018-10-24 | RMLP2C100015 SS | 478.62d | 0d | PRC | 2189 |
| RMLP2C100015 |  | PO Issuance Process for Power Factor Correction System | 10d | 2018-10-15 | 2018-10-24 | RMLP2C100016 SS | 478.62d | 0d | PRC | 2190 |
| RMLP2C100016 |  | PO Issuance Process for Wiring and Device System | 10d | 2018-10-15 | 2018-10-24 | RMLP2C100017 SS | 478.62d | 0d | PRC | 2191 |
| RMLP2C100017 |  | PO Issuance Process for Lighting System | 10d | 2018-10-15 | 2018-10-24 | RMLP2C100011 SS | 478.62d | 0d | PRC | 2192 |
|  | 2 | **FIRE FIGHTING SYSTEM** |  | 2018-09-09 | 2018-10-24 |  |  |  |  |  |
| RMLP2C100021 |  | PO Issuance Process for Fire Extinguisher C02 & ABC | 10d | 2018-09-09 | 2018-09-18 | RMLP2C100022 SS | 475.5d | 0d | PRC |  |
| RMLP2C100022 |  | PO Issuance Process for Valves and Ancillaries (Gate Valves, Check Valve, Inspection Test & Drain Valve) | 10d | 2018-09-09 | 2018-09-18 | RMLP2C100028 SS | 475.5d | 0d | PRC |  |
| RMLP2C100018 |  | PO Issuance Process for Fire Hose Cabinet | 10d | 2018-10-15 | 2018-10-24 | RMLP2C100019 SS | 478.62d | 0d | PRC |  |
| RMLP2C100019 |  | PO Issuance Process for Fire Department Connection | 10d | 2018-10-15 | 2018-10-24 | RMLP2C100020 SS | 478.62d | 0d | PRC |  |
| RMLP2C100020 |  | PO Issuance Process for Street Pillar Hydrant & Tank Fill connector | 10d | 2018-10-15 | 2018-10-24 | RMLP2C100021 SS, RMLE2C100160 (other project) SS, RMLE2C100160 | 436.62d | 0d | PRC |  |
| RMLP2C100023 |  | PO Issuance Process for Fire Suppression Sprinkler (Pendant, Sidewall and Upright Sprinklers) | 10d | 2018-10-15 | 2018-10-24 | RMLP2C100018 SS | 478.62d | 0d | PRC | 2193 |

| ID | WBS | Activity | Duration | Start | Finish | Predecessors | Total float | Free float | MSP Activity ID | MEP-Phase |
| --- | --- | --- | --- | --- | --- | --- | --- | --- | --- | --- |
|  | 3 | **BULK MATERIALS** |  | 2018-08-30 | 2018-09-18 |  |  |  |  |  |
|  | 1 | **HVAC SYSTEM** |  | 2018-09-09 | 2018-09-18 |  |  |  |  |  |
| RMLP2C100024 |  | PO Issuance Process for Bulk Material (Insulation) | 5d | 2018-09-09 | 2018-09-13 | RMLP2C100026 SS | 475.5d | 0d | 456 | PRC |
| RMLP2C100025 |  | PO Issuance Process for Duct Accessories (VD,MVD, BDD, FD, MSD,MFSD) | 10d | 2018-09-09 | 2018-09-18 | RMLP2C100034 SS | 475.5d | 0d | 459 | PRC |
| RMLP2C100026 |  | PO Issuance Process for Pipe Insulation | 10d | 2018-09-09 | 2018-09-18 | RMLP2C100027 SS | 475.5d | 0d | 462 | PRC |
| RMLP2C100027 |  | PO Issuance Process for Valves and Ancillaries | 10d | 2018-09-09 | 2018-09-18 | RMLP2C100030 SS | 475.5d | 0d | 462 | PRC |
| RMLP2C100028 |  | PO Issuance Process for Duct Hangers and Supports | 5d | 2018-09-09 | 2018-09-13 | RMLP2C100029 SS | 475.5d | 0d | 453 | PRC |
| RMLP2C100029 |  | PO Issuance Process for Bulk Material (Duct / Cladding) | 5d | 2018-09-09 | 2018-09-13 | RMLP2C100024 SS | 475.5d | 0d | 456 | PRC |
| RMLP2C100030 |  | PO Issuance Process for Air Outlets (Grills, Diffusers etc..) | 10d | 2018-09-09 | 2018-09-18 | RMLP2C100031 SS | 475.5d | 0d | 459 | PRC |
| RMLP2C100031 |  | PO Issuance Process for Pipe Fittings | 10d | 2018-09-09 | 2018-09-18 | RMLP2C100025 SS | 475.5d | 0d | 462 | PRC |
|  | 4 | **PLUMBING SYSTEM** |  | 2018-09-09 | 2018-09-18 |  |  |  |  |  |
| RMLP2C100032 |  | PO Issuance Process for Pipe Insulation | 10d | 2018-09-09 | 2018-09-18 | RMLP2C100033 SS | 475.5d | 0d | 469 | PRC |
| RMLP2C100033 |  | PO Issuance Process for Valves and Accessories | 10d | 2018-09-09 | 2018-09-18 | RMLP2C100038 SS | 475.5d | 0d | 469 | PRC |
| RMLP2C100034 |  | PO Issuance Process for Supports and Accessories | 10d | 2018-09-09 | 2018-09-18 | RMLP2C100035 SS | 475.5d | 0d | 466 | PRC |
| RMLP2C100035 |  | PO Issuance Process for Pipe and Fittings | 10d | 2018-09-09 | 2018-09-18 | RMLP2C100032 SS | 475.5d | 0d | 469 | PRC |
|  | 3 | **ELECTRICAL / CONTROLS** |  | 2018-09-09 | 2018-09-13 |  |  |  |  |  |
| RMLP2C100036 |  | PO Issuance Process for Containment (Cable Tray, Cable Trunking and Cable | 5d | 2018-09-09 | 2018-09-13 | RMLP2C100037 SS | 430.5d | 0d | 473 | PRC |
| RMLP2C100037 |  | PO Issuance Process for Containment (Cables) | 5d | 2018-09-09 | 2018-09-13 | RMLP2C100041 SS | 430.5d | 0d | 473 | PRC |
| RMLP2C100038 |  | PO Issuance Process for Containment (Conduit) | 5d | 2018-09-09 | 2018-09-13 | RMLP2C100039 SS | 430.5d | 0d | 473 | PRC |
| RMLP2C100039 |  | PO Issuance Process for Earthing and Bonding Material | 5d | 2018-09-09 | 2018-09-13 | RMLP2C100036 SS | 430.5d | 0d | 476 | PRC |
|  | 2 | **FIRE FIGHTING SYSTEM** |  | 2018-08-30 | 2018-09-18 |  |  |  |  |  |
| RMLP2C100042 |  | PO Issuance Process for Pipe and Fittings | 10d | 2018-08-30 | 2018-09-09 | RMLE2C100113 (other project) | 430.5d | 0d | 486 | PRC |
| RMLP2C100040 |  | PO Issuance Process for Valves and Ancillaries | 10d | 2018-09-09 | 2018-09-18 | RMLP2C100042 | 430.5d | 0d | 486 | PRC |
| RMLP2C100041 |  | PO Issuance Process for Hangers and Supports | 6d | 2018-09-09 | 2018-09-15 | RMLP2C100040 SS | 430.5d | 0d | 483 | PRC |

| ID | WBS | Activity | Duration | Start | Finish | Predecessors | Total float | Free float | MEP-Phase | MSP Activity ID |
| --- | --- | --- | --- | --- | --- | --- | --- | --- | --- | --- |
|  | 2 | **Manufacturing and Delivery** |  | 2018-08-30 | 2019-02-13 |  |  |  |  |  |
|  | 1.3.1.3.1 | **LONG LEAD ITEMS** |  | 2018-09-09 | 2019-02-13 |  |  |  |  |  |
|  | 1.3.1.3.1.1.3.1.1 | **HVAC SYSTEM** |  | 2018-10-24 | 2019-02-13 |  |  |  |  |  |
| RMLP2C100043 |  | Supply and Delivery of Air Curtains & Air Ionization Units | 110d | 2018-10-24 | 2019-02-04 | RMLP2C100001 SS | 488.62d | 134.62d | PRC |  |
| RMLP2C100044 |  | Supply and Delivery of AHU | 110d | 2018-10-24 | 2019-02-04 | RMLP2C100002 SS | 483.62d | 130.62d | PRC | 1538 |
| RMLP2C100045 |  | Supply and Delivery of ACCU | 120d | 2018-10-24 | 2019-02-13 | RMLP2C100003 SS | 491.62d | 130.62d | PRC | 1537 |
| RMLP2C100046 |  | Supply and Delivery of CRAC Units | 120d | 2018-10-24 | 2019-02-13 | RMLP2C100004 SS | 488.62d | 130.62d | PRC | 249 |
| RMLP2C100047 |  | Supply and Delivery of Fan Coil Units | 120d | 2018-10-24 | 2019-02-13 | RMLP2C100005 SS | 488.62d | 130.62d | PRC | 250 |
| RMLP2C100048 |  | Supply and Delivery of Exhaust Fans | 120d | 2018-10-24 | 2019-02-13 | RMLP2C100006 SS | 493.62d | 130.62d | PRC | 255 |
|  | 1.3.1.3.1.1.3.1.2 | **PLUMBING SYSTEM** |  | 2018-10-15 | 2018-12-27 |  |  |  |  |  |
| RMLP2C100049 |  | Supply and Delivery of Tank Circulation Pump | 60d | 2018-10-15 | 2018-12-10 | RMLP2C100007 SS | 514.62d | 157.62d | PRC | 302 |
| RMLP2C100050 |  | Supply and Delivery of GRP Water Storage Tank | 60d | 2018-10-15 | 2018-12-10 | RMLP2C100008 SS | 519.62d | 180.62d | PRC | 303 |
| RMLP2C100051 |  | Supply and Delivery of Water treatment Plant | 78d | 2018-10-15 | 2018-12-27 | RMLP2C100009 SS | 519.62d | 180.62d | PRC | 304 |
| RMLP2C100052 |  | Supply and Delivery of Plumbing Fixtures | 75d | 2018-10-15 | 2018-12-24 | RMLP2C100010 SS | 519.62d | 168.62d | PRC | 306 |
|  | 1.3.1.3.1.1.3.1.3 | **ELECTRICAL / CONTROLS** |  | 2018-10-15 | 2019-02-04 |  |  |  |  |  |
| RMLP2C100053 |  | Supply and Delivery of Central Battery System | 112d | 2018-10-15 | 2019-01-28 | RMLP2C100011 SS | 499.62d | 203.62d | PRC |  |
| RMLP2C100054 |  | Supply and Delivery of Access control System (Door locks Only) | 90d | 2018-10-15 | 2019-01-07 | RMLP2C100012 SS | 493.62d | 218.62d | PRC |  |
| RMLP2C100055 |  | Supply and Delivery of MCC'S, Switch Boards and Panel Boards | 100d | 2018-10-15 | 2019-01-16 | RMLP2C100013 SS | 478.62d | 203.62d | PRC | 335 |
| RMLP2C100056 |  | Supply and Delivery of Cooper Bus Duct System | 90d | 2018-10-15 | 2019-01-07 | RMLP2C100014 SS | 485.62d | 154.62d | PRC | 336 |
| RMLP2C100057 |  | Supply and Delivery of Power Factor Correction System | 95d | 2018-10-15 | 2019-01-12 | RMLP2C100015 SS | 478.62d | 203.62d | PRC | 337 |
| RMLP2C100058 |  | Supply and Delivery of Wiring and Device System | 120d | 2018-10-15 | 2019-02-04 | RMLP2C100016 SS | 493.62d | 218.62d | PRC | 340 |
| RMLP2C100059 |  | Supply and Delivery of Lighting System | 72d | 2018-10-15 | 2018-12-22 | RMLP2C100017 SS | 481.62d | 203.62d | PRC | 343 |
|  | 1.3.1.3.1.1.3.1.4 | **FIRE FIGHTING SYSTEM** |  | 2018-09-09 | 2019-01-28 |  |  |  |  |  |
| RMLP2C100063 |  | Supply and Delivery of Fire Extinguisher C02 & ABC | 90d | 2018-09-09 | 2018-12-02 | RMLP2C100021 SS | 550.5d | 255.5d | PRC |  |
| RMLP2C100064 |  | Supply and Delivery of Valves and Ancillaries (Gate Valves, Check Valve, Inspection Test & Drain Valve) | 72d | 2018-09-09 | 2018-11-15 | RMLP2C100022 SS | 505.5d | 210.5d | PRC |  |
| RMLP2C100060 |  | Supply and Delivery of Fire Hose Cabinet | 90d | 2018-10-15 | 2019-01-07 | RMLP2C100018 SS | 516.62d | 221.62d | PRC |  |
| RMLP2C100061 |  | Supply and Delivery of Fire Department Connection | 90d | 2018-10-15 | 2019-01-07 | RMLP2C100019 SS | 511.62d | 226.62d | PRC |  |
| RMLP2C100062 |  | Supply and Delivery of Street Pillar Hydrant & Tank Fill connector | 90d | 2018-10-15 | 2019-01-07 | RMLP2C100020 SS | 516.62d | 216.62d | PRC |  |
| RMLP2C100065 |  | Supply and Delivery of Fire Suppression Sprinkler (Pendant, Sidewall and Upright Sprinklers) | 90d | 2018-10-15 | 2019-01-07 | RMLP2C100023 SS | 496.62d | 201.62d | PRC | 422 |
| RMLP2C100066 |  | Supply and Delivery of Fire Pumps | 112d | 2018-10-15 | 2019-01-28 | RMLP2C100020 SS | 436.62d | 141.62d |  |  |

| ID | WBS | Activity | Duration | Start | Finish | Predecessors | Total float | Free float | MSP Activity ID | MEP-Phase |
| --- | --- | --- | --- | --- | --- | --- | --- | --- | --- | --- |
|  | 1.3.1.3.2 | **BULK MATERIALS** |  | 2018-08-30 | 2018-11-04 |  |  |  |  |  |
|  | 1.3.1.3.2.1.3.2.1.1. | **HVAC SYSTEM** |  | 2018-09-09 | 2018-11-04 |  |  |  |  |  |
| RMLP2C100067 |  | Supply and Delivery of Bulk Material (Insulation) | 42d | 2018-09-09 | 2018-10-18 | RMLP2C100024 SS | 522.5d | 170.5d | 457 | PRC |
| RMLP2C100068 |  | Supply and Delivery of Duct Accessories (VD,MVD, BDD, FD, MSD,MFSD) | 60d | 2018-09-09 | 2018-11-04 | RMLP2C100025 SS | 518.5d | 179.5d | 460 | PRC |
| RMLP2C100069 |  | Supply and Delivery of Pipe Insulation | 60d | 2018-09-09 | 2018-11-04 | RMLP2C100026 SS | 534.5d | 193.5d | 463 | PRC |
| RMLP2C100070 |  | Supply and Delivery of Valves and Ancillaries | 60d | 2018-09-09 | 2018-11-04 | RMLP2C100027 SS | 524.5d | 183.5d | 463 | PRC |
| RMLP2C100071 |  | Supply and Delivery of Duct Hangers and Supports | 32d | 2018-09-09 | 2018-10-09 | RMLP2C100028 SS | 504.5d | 165.5d | 454 | PRC |
| RMLP2C100072 |  | Supply and Delivery of Bulk Material (Duct / Cladding) | 42d | 2018-09-09 | 2018-10-18 | RMLP2C100029 SS | 506.5d | 167.5d | 457 | PRC |
| RMLP2C100073 |  | Supply and Delivery of Air Outlets (Grills, Diffusers etc..) | 60d | 2018-09-09 | 2018-11-04 | RMLP2C100030 SS | 530.5d | 191.5d | 460 | PRC |
| RMLP2C100074 |  | Supply and Delivery of Pipe Fittings | 60d | 2018-09-09 | 2018-11-04 | RMLP2C100031 SS | 512.5d | 171.5d | 463 | PRC |
|  | 1.3.1.3.2.1.3.2.1.-1 | **PLUMBING SYSTEM** |  | 2018-09-09 | 2018-10-18 |  |  |  |  |  |
| RMLP2C100075 |  | Supply and Delivery of Pipe Insulation | 42d | 2018-09-09 | 2018-10-18 | RMLP2C100032 SS | 510.5d | 171.5d | 470 | PRC |
| RMLP2C100076 |  | Supply and Delivery of Valves and Accessories | 42d | 2018-09-09 | 2018-10-18 | RMLP2C100033 SS | 530.5d | 191.5d | 470 | PRC |
| RMLP2C100077 |  | Supply and Delivery of Supports and Accessories | 30d | 2018-09-09 | 2018-10-07 | RMLP2C100034 SS | 504.5d | 165.5d | 467 | PRC |
| RMLP2C100078 |  | Supply and Delivery of Pipe and Fittings | 42d | 2018-09-09 | 2018-10-18 | RMLP2C100035 SS | 510.5d | 171.5d | 470 | PRC |
|  | 1.3.1.3.2.1.3.2.1.-2 | **ELECTRICAL / CONTROLS** |  | 2018-09-09 | 2018-11-04 |  |  |  |  |  |
| RMLP2C100079 |  | Supply and Delivery of Containment (Cable Tray, Cable Trunking and Cable | 60d | 2018-09-09 | 2018-11-04 | RMLP2C100036 SS | 494.5d | 173.5d | 474 | PRC |
| RMLP2C100080 |  | Supply and Delivery of Containment (Cables) | 60d | 2018-09-09 | 2018-11-04 | RMLP2C100037 SS | 462.5d | 197.5d | 474 | PRC |
| RMLP2C100081 |  | Supply and Delivery of Containment (Conduit) | 60d | 2018-09-09 | 2018-11-04 | RMLP2C100038 SS | 430.5d | 165.5d | 474 | PRC |
| RMLP2C100082 |  | Supply and Delivery of Earthing and Bonding Material | 60d | 2018-09-09 | 2018-11-04 | RMLP2C100039 SS | 442.5d | 177.5d | 477 | PRC |
|  | 1.3.1.3.2.1.3.2.1.-3 | **FIRE FIGHTING SYSTEM** |  | 2018-08-30 | 2018-11-04 |  |  |  |  |  |
| RMLP2C100085 |  | Supply and Delivery of Pipe and Fittings | 60d | 2018-08-30 | 2018-10-25 | RMLP2C100042 SS | 475.5d | 190.5d | 487 | PRC |
| RMLP2C100083 |  | Supply and Delivery of Valves and Ancillaries | 60d | 2018-09-09 | 2018-11-04 | RMLP2C100040 SS | 495.5d | 210.5d | 487 | PRC |
| RMLP2C100084 |  | Supply and Delivery of Hangers and Supports | 54d | 2018-09-09 | 2018-10-29 | RMLP2C100041 SS | 450.5d | 165.5d | 484 | PRC |

| ID | WBS | Activity | Type | Duration | Start | Finish | Predecessors | Total float | Free float | Calendar | Resources | Cost | Discipline | MILESTONE | LOCATION | AREA |
| --- | --- | --- | --- | --- | --- | --- | --- | --- | --- | --- | --- | --- | --- | --- | --- | --- |
|  | 5 | **CONSTRUCTION** |  |  | 2018-09-01 | 2020-09-01 |  |  |  |  |  |  |  |  |  |  |
|  | 1 | **CIVIL / STRUCTURAL WORKS** |  |  | 2018-09-01 | 2020-01-16 |  |  |  |  |  |  |  |  |  |  |
|  | 1 | **SOUTH MAIN BOX Concrete Works (Zone 8 to Zone 11)** |  |  | 2018-09-01 | 2019-05-06 |  |  |  |  |  |  |  |  |  |  |
| LOE-SUM1-010 |  | South . P06 - Concrete Works | level of effort | 60d | 2018-09-01 | 2018-10-25 | C1C1111F5S330 SS | 10d | 0d | Saudi |  |  | Civil |  |  |  |
|  | 3 | **South - 1st Stage Concrete Concrete on TRACK ACCESS LINE** |  |  | 2018-10-04 | 2018-10-25 |  |  |  |  |  |  |  |  |  |  |
| C1C1111F5S310 |  | MS1F5 - 1st stage Concrete at P07- Zone-8 & 9 |  | 15d | 2018-10-04 | 2018-10-17 | C1C1111F5S410, C1C1111F5S380 FF, C1C1111F5S380 | 0.75d | 0d |  | Steel Fixer [600 h]; Concrete Casting [161.46 CUM]; Helper [429 h]; Carpenter [600 h]; Mason [600 h] | 156.7 | Civil | 02 | MB |  |
| C1C1111F5S320 |  | MS1F5 - 1st stage Concrete complete P07- Zone-10 & 11 |  | 15d | 2018-10-13 | 2018-10-25 | C1C1111F5S310 FF+8.75d, C1C1111F5S380, LOE-SUM1-010 FF | 10d |  |  | Helper [350.84 h]; Steel Fixer [584.74 h]; Concrete Casting [166.31 CUM]; Carpenter [584.74 h]; Mason [701.68 h] | 156.21 | Civil | 02 | MB |  |
|  | 4 | **Platform Level P06 South ( AREA-4 to AREA-5 )** |  |  | 2018-09-01 | 2018-10-25 |  |  |  |  |  |  |  |  |  |  |
|  | 1 | **Platform Level ( P06 . AREA-4, 37.5 L , 616 m3 )** |  |  | 2018-09-01 | 2018-10-03 |  |  |  |  |  |  |  |  |  |  |
| C1C1111F5S330 |  | P06- AREA-4 SE Formwork and Slab fixing |  | 7.5d | 2018-09-01 | 2018-09-06 | MOB1F5010 SS+2.5d | 0d |  |  | Helper [343.2 h]; Carpenter [686.4 h] | 72.38 | Civil | 02 | MB | 4 |
| C1C1111F5S340 |  | P06-AREA-4 SW Formwork and Slab fixing |  | 7.5d | 2018-09-01 | 2018-09-06 | C1C1111F5S330 SS | 0d |  |  | Helper [343.2 h]; Carpenter [686.4 h] | 72.38 | Civil | 02 | MB | 4 |
| C1C1111F5S350 |  | P06- AREA-4 SE Rebar fixing |  | 6.25d | 2018-09-08 | 2018-09-12 | C1C1111F5S330, C1C1111F5S340 SS+5d | 0d |  |  | Helper [343.2 h]; Steel Fixer [715 h] | 74.39 | Civil | 02 | MB | 4 |
| C1C1111F5S360 |  | P06-AREA-4 SW Rebar fixing |  | 6.25d | 2018-09-08 | 2018-09-12 | C1C1111F5S340 | 0d |  |  | Helper [343.2 h]; Steel Fixer [715 h] | 74.39 | Civil | 02 | MB | 4 |
| C1C1111F5S370 |  | P06- AREA-4 SE Concrete Casting Slab |  | 2.5d | 2018-09-13 | 2018-09-15 | C1C1111F5S350, C1C1111F5S360 | 0d |  |  | Mason [572 h]; Helper [143 h]; Concrete Casting [97.95 CUM] | 50.26 | Civil | 02 | MB | 4 |
| C1C1111F5S380 |  | P06-AREA-4 SW Concrete Casting Slab |  | 2.5d | 2018-09-15 | 2018-09-16 | C1C1111F5S370 FF+1.25d | 0d |  |  | Mason [572 h]; Helper [143 h]; Concrete Casting [97.95 CUM] | 50.26 | Civil | 02 | MB | 4 |
| C1C1111F5S390 |  | P06- AREA-4 Rebar fixing wall / column / staircase |  | 10d | 2018-09-17 | 2018-09-25 | C1C1111F5S380 | 0.75d | 0d |  | Helper [457.6 h]; Steel Fixer [800 h] | 88.41 | Civil | 02 | MB | 4 |
| C1C1111F5S400 |  | P06- AREA-4 Formwork fixing wall / column / staircase |  | 10d | 2018-09-23 | 2018-10-01 | C1C1111F5S390 FF+6.25d | 0.75d | 0d |  | Helper [457.6 h]; Carpenter [800 h] | 88.41 | Civil | 02 | MB | 4 |
| C1C1111F5S410 |  | P06- AREA-4 Concrete Casting wall / column / staircase |  | 2.5d | 2018-10-02 | 2018-10-03 | C1C1111F5S400, MOB1F5030, LOE-SUM1-010 FF | 0.75d | 0d |  | Mason [429 h]; Helper [143 h]; Concrete Casting [518.83 CUM] | 40.21 | Civil | 02 | MB | 4 |
|  | 2 | **Platform Level ( P06 . AREA-5, 24 L , 475 m3 )** |  |  | 2018-09-17 | 2018-10-25 |  |  |  |  |  |  |  |  |  |  |
| C1C1111F5S420 |  | P06- AREA-5 SE Formwork and Slab fixing |  | 7.5d | 2018-09-17 | 2018-09-23 | C1C1111F5S380 | 0d |  |  | Helper [357.5 h]; Carpenter [686.4 h] | 73.38 | Civil | 02 | MB | 5 |
| C1C1111F5S430 |  | P06-AREA-5 SW Formwork and Slab fixing |  | 7.5d | 2018-09-19 | 2018-09-25 | C1C1111F5S420 SS+2.5d | 0d |  |  | Helper [357.5 h]; Carpenter [686.4 h] | 73.38 | Civil | 02 | MB | 5 |
| C1C1111F5S440 |  | P06- AREA-5 SE Rebar fixing |  | 7.5d | 2018-09-26 | 2018-10-02 | C1C1111F5S430 | 0d |  |  | Helper [343.2 h]; Steel Fixer [858 h] | 84.45 | Civil | 02 | MB | 5 |
| C1C1111F5S450 |  | P06-AREA-5 SW Rebar fixing |  | 7.5d | 2018-09-30 | 2018-10-06 | C1C1111F5S440 SS+3.75d, C1C1111F5S430, C1C1111F5S430 SS+3.75d | 0d |  |  | Helper [343.2 h]; Steel Fixer [858 h] | 84.45 | Civil | 02 | MB | 5 |
| C1C1111F5S460 |  | P06- AREA-5 SE Concrete Casting Slab |  | 2.5d | 2018-10-03 | 2018-10-04 | C1C1111F5S440 | 0d |  |  | Mason [572 h]; Helper [143 h]; Concrete Casting [64.58 CUM] | 50.26 | Civil | 02 | MB | 5 |
| C1C1111F5S470 |  | P06-AREA-5 SW Concrete Casting Slab |  | 2.5d | 2018-10-06 | 2018-10-07 | C1C1111F5S450 FF+1.25d, C1C1111F5S460 | 0d |  |  | Mason [343.2 h]; Helper [214.5 h]; Concrete Casting [64.58 CUM] | 39.21 | Civil | 02 | MB | 5 |
| C1C1111F5S480 |  | P06- AREA-5 Rebar fixing wall / column / staircase |  | 8.75d | 2018-10-08 | 2018-10-15 | C1C1111F5S460, C1C1111F5S470, CM010 FF | 0d |  |  | Helper [400.4 h]; Steel Fixer [700 h] | 77.36 | Civil | 02 | MB | 5 |
| C1C1111F5S490 |  | P06- AREA-5 Formwork fixing wall / column / staircase |  | 8.75d | 2018-10-16 | 2018-10-23 | C1C1111F5S480 | 0d |  |  | Helper [343.2 h]; Carpenter [700 h] | 73.34 | Civil | 02 | MB | 5 |
| C1C1111F5S500 |  | P06- AREA-5 Concrete Casting wall / column / staircase |  | 2.5d | 2018-10-24 | 2018-10-25 | C1C1111F5S490, LOE-SUM1-010 FF | 0d |  |  | Mason [429 h]; Helper [143 h]; Concrete Casting [667.38 CUM] | 40.21 | Civil | 02 | MB | 5 |

| ID | WBS | Activity | Type | Duration | Start | Finish | Predecessors | Total float | Free float | Calendar | Resources | Cost | Discipline | MILESTONE | AREA | LOCATION |
| --- | --- | --- | --- | --- | --- | --- | --- | --- | --- | --- | --- | --- | --- | --- | --- | --- |
|  | 5 | **Mezzanine Level South ( AREA-4 to AREA-5 )** |  |  | 2018-10-02 | 2018-11-24 |  |  |  |  |  |  |  |  |  |  |
| LOE-SUM1-020 |  | South . B05 - Concrete Works | level of effort | 57.5d | 2018-10-02 | 2018-11-24 | C1C1111F5S510 SS | 0d |  | Saudi |  |  | Civil |  |  |  |
|  | 1 | **Mezzanine Level ( B05 . AREA-4, 37.5 L , 570 m3 )** |  |  | 2018-10-02 | 2018-11-10 |  |  |  |  |  |  |  |  |  |  |
| C1C1111F5S510 |  | B05 - AREA-4 SE Formwork and Slab fixing |  | 7.5d | 2018-10-02 | 2018-10-08 | C1C1111F5S410 SS | 7d | 0d |  | Helper [343.2 h]; Carpenter [686.4 h] | 72.38 | Civil | 02 | 4 | MB |
| C1C1111F5S520 |  | B05 - AREA-4 SW Formwork and Slab fixing |  | 7.5d | 2018-10-02 | 2018-10-08 | C1C1111F5S510 SS | 7d | 0d |  | Helper [343.2 h]; Carpenter [686.4 h] | 72.38 | Civil | 02 | 4 | MB |
| C1C1111F5S530 |  | B05 - AREA-4 SE Rebar fixing |  | 7.5d | 2018-10-04 | 2018-10-10 | C1C1111F5S510 SS+2.5d, C1C1111F5S520 SS+2.5d | 8.25d | 7.5d |  | Helper [343.2 h]; Steel Fixer [858 h] | 84.45 | Civil | 02 | 4 | MB |
| C1C1111F5S540 |  | B05 - AREA-4 SW Rebar fixing |  | 7.5d | 2018-10-04 | 2018-10-10 | C1C1111F5S520 SS+2.5d | 7d | 0d |  | Helper [343.2 h]; Steel Fixer [858 h] | 84.45 | Civil | 02 | 4 | MB |
| C1C1111F5S560 |  | B05 - AREA-4 SW Concrete Casting Slab |  | 2.5d | 2018-10-11 | 2018-10-13 | C1C1111F5S540 FF, C1C1111F5S540 | 7d | 0d |  | Mason [572 h]; Helper [114.4 h]; Concrete Casting [38.97 CUM] | 48.25 | Civil | 02 | 4 | MB |
| C1C1111F5S550 |  | B05 - AREA-4 SE Concrete Casting Slab |  | 2.5d | 2018-10-18 | 2018-10-20 | C1C1111F5S540 SS+1.25d, C1C1111F5S310, C1C1111F5S530 | 0.75d | 0d |  | Mason [572 h]; Helper [114.4 h]; Concrete Casting [39.83 CUM] | 48.25 | Civil | 02 | 4 | MB |
|  | 1 | **Mezzanine Level ( B05 AREA-4 .Walls 3.0 ht )** |  |  | 2018-10-14 | 2018-11-10 |  |  |  |  |  |  |  |  |  |  |
| C1C1111F5S570 |  | B05- AREA-4 Rebar fixing column |  | 5d | 2018-10-14 | 2018-10-17 | C1C1111F5S560 SS+2.5d | 15.75d | 0d |  | Helper [228.8 h]; Steel Fixer [572 h] | 56.29 | Civil | 02 | 4 | MB |
| C1C1111F5S590 |  | B05- AREA-4 Formwork fixing column |  | 5d | 2018-10-18 | 2018-10-22 | C1C1111F5S570 | 15.75d | 0d |  | Helper [228.8 h]; Carpenter [343.2 h] | 40.21 | Civil | 02 | 4 | MB |
| C1C1111F5S580 |  | B05- AREA-4 Waterproofing wall (not by ZSCC) |  | 6.25d | 2018-10-21 | 2018-10-25 | C1C1111F5S560, C1C1111F5S550 | 0.75d | 0d |  |  |  | Civil | 02 | 4 | MB |
| C1C1111F5S610 |  | B05- AREA-4 Concrete Casting column |  | 2.5d | 2018-10-23 | 2018-10-24 | C1C1111F5S590 | 15.75d | 15d |  | Mason [429 h]; Helper [143 h]; Concrete Casting [220.67 CUM] | 40.21 | Civil | 02 | 4 | MB |
| C1C1111F5S600 |  | B05- AREA-4 Rebar fixing wall |  | 8.75d | 2018-10-25 | 2018-11-01 | C1C1111F5S580 FF+7.5d | 0.75d | 0d |  | Helper [400.4 h]; Steel Fixer [700 h] | 77.36 | Civil | 02 | 4 | MB |
| C1C1111F5S620 |  | B05- AREA-4 Formwork fixing wall |  | 8.75d | 2018-10-31 | 2018-11-07 | C1C1111F5S600 FF+6.25d | 0.75d | 0d |  | Helper [400.4 h]; Carpenter [700 h] | 77.36 | Civil | 02 | 4 | MB |
| C1C1111F5S630 |  | B05- AREA-4 Concrete Casting & Striking wall |  | 2.5d | 2018-11-08 | 2018-11-10 | C1C1111F5S320 FF, C1C1111F5S620, C1C1111F5S610, LOE-SUM1-020 FF | 0.75d | 0d |  | Mason [429 h]; Helper [143 h]; Concrete Casting [184.07 CUM] | 40.21 | Civil | 02 | 4 | MB |
|  | 2 | **Mezzanine Level ( B05 . AREA-5, 24 L , 542 m3 )** |  |  | 2018-10-27 | 2018-11-24 |  |  |  |  |  |  |  |  |  |  |
| C1C1111F5S640 |  | B05 - AREA-5 SE Formwork and Slab fixing |  | 6.25d | 2018-10-27 | 2018-10-31 | C1C1111F5S500 | 0d |  |  | Helper [343.2 h]; Carpenter [686.4 h] | 72.38 | Civil | 02 | 5 | MB |
| C1C1111F5S650 |  | B05 - AREA-5 SW Formwork and Slab fixing |  | 6.25d | 2018-10-27 | 2018-10-31 | C1C1111F5S640 SS | 0d |  |  | Helper [343.2 h]; Carpenter [686.4 h] | 72.38 | Civil | 02 | 5 | MB |
| C1C1111F5S655 |  | B05 - AREA-5 SE Rebar fixing |  | 6.25d | 2018-10-30 | 2018-11-04 | C1C1111F5S650 SS+3.75d | 0d |  |  | Helper [343.2 h]; Steel Fixer [858 h] | 84.45 | Civil | 02 | 5 | MB |
| C1C1111F5S670 |  | B05 - AREA-5 SW Rebar fixing |  | 6.25d | 2018-10-30 | 2018-11-04 | C1C1111F5S650 SS+3.75d | 0d |  |  | Helper [343.2 h]; Steel Fixer [858 h] | 84.45 | Civil | 02 | 5 | MB |
| C1C1111F5S680 |  | B05 - AREA-5 SE Concrete Casting Slab |  | 2.5d | 2018-11-05 | 2018-11-06 | C1C1111F5S670 SS+1.25d, C1C1111F5S320, C1C1111F5S655 | 0d |  |  | Mason [572 h]; Helper [114.4 h]; Concrete Casting [43.06 CUM] | 48.25 | Civil | 02 | 5 | MB |
| C1C1111F5S690 |  | B05 - AREA-5 SW Concrete Casting Slab |  | 2.5d | 2018-11-05 | 2018-11-06 | C1C1111F5S680 FF, C1C1111F5S670 | 0d |  |  | Mason [572 h]; Helper [114.4 h]; Concrete Casting [44.13 CUM] | 48.25 | Civil | 02 | 5 | MB |

| ID | WBS | Activity | Type | Duration | Start | Finish | Predecessors | Total float | Free float | Calendar | Resources | Cost | MILESTONE | Discipline | AREA | LOCATION |
| --- | --- | --- | --- | --- | --- | --- | --- | --- | --- | --- | --- | --- | --- | --- | --- | --- |
|  | 1 | **Mezzanine Level ( B05 AREA-5 .Walls 3.0 ht )** |  |  | 2018-11-07 | 2018-11-24 |  |  |  |  |  |  |  |  |  |  |
| C1C1111F5S700 |  | B05- AREA-5 Rebar fixing column |  | 5d | 2018-11-07 | 2018-11-11 | C1C1111F5S690 | 3.75d | 0d |  | Helper [228.8 h]; Steel Fixer [572 h] | 56.29 | 02 | Civil | 5 | MB |
| C1C1111F5S710 |  | B05- AREA-5 Waterproofing wall (not by ZSCC) |  | 7.5d | 2018-11-07 | 2018-11-13 | C1C1111F5S690 | 0d |  |  |  |  | 02 | Civil | 5 | MB |
| C1C1111F5S720 |  | B05- AREA-5 Formwork fixing column |  | 5d | 2018-11-12 | 2018-11-15 | C1C1111F5S700, C1C1111F5S710 SS+2.5d | 3.75d | 0d |  | Helper [228.8 h]; Carpenter [343.2 h] | 40.21 | 02 | Civil | 5 | MB |
| C1C1111F5S730 |  | B05- AREA-5 Rebar fixing wall |  | 7.5d | 2018-11-12 | 2018-11-18 | C1C1111F5S710 FF+5d | 0d |  |  | Helper [400.4 h]; Steel Fixer [720 h] | 78.77 | 02 | Civil | 5 | MB |
| C1C1111F5S740 |  | B05- AREA-5 Concrete Casting column |  | 2.5d | 2018-11-17 | 2018-11-18 | C1C1111F5S720, C1C1111F5S730 FF | 3.75d |  |  | Mason [572 h]; Helper [143 h]; Concrete Casting [188.37 CUM] | 50.26 | 02 | Civil | 5 | MB |
| C1C1111F5S750 |  | B05- AREA-5 Formwork fixing wall |  | 7.5d | 2018-11-17 | 2018-11-22 | C1C1111F5S730 FF+5d | 0d |  |  | Helper [400.4 h]; Carpenter [720 h] | 78.77 | 02 | Civil | 5 | MB |
| C1C1111F5S760 |  | B05- AREA-5 Concrete Casting & Striking wall |  | 2.5d | 2018-11-22 | 2018-11-24 | C1C1111F5S750 FF+1.25d, C1C1111F5S740, LOE-SUM1-020 FF | 0d |  |  | Mason [429 h]; Helper [143 h]; Concrete Casting [175.46 CUM] | 40.21 | 02 | Civil | 5 | MB |
|  | 4 | **Mezzanine Level ( B05 . OTE AREA-4 )** |  |  | 2018-10-18 | 2018-11-13 |  |  |  |  |  |  |  |  |  |  |
|  | 3 | **Mezzanine Level ( B05 . OTE AREA-4 ) Lower Part** |  |  | 2018-10-18 | 2018-10-31 |  |  |  |  |  |  |  |  |  |  |
| C1C1111F5S770 |  | B05- AREA-4 Formwork |  | 6.25d | 2018-10-18 | 2018-10-23 | C1C1111F5S310, C1C1111F5S560 | 2d | 0d |  | Helper [500 h]; Carpenter [600 h] | 77.33 | 02 | Civil | 4 | MB |
| C1C1111F5S780 |  | B05-AREA-4 Rebar fixing |  | 6.25d | 2018-10-24 | 2018-10-29 | C1C1111F5S770 | 2d | 0d |  | Helper [500 h]; Steel Fixer [600 h] | 77.33 | 02 | Civil | 4 | MB |
| C1C1111F5S790 |  | B05-AREA-4 Concrete Casting Slab |  | 2.5d | 2018-10-30 | 2018-10-31 | C1C1111F5S780 | 2d | 0d |  | Mason [171.6 h]; Concrete Casting [33.37 CUM]; Helper [114.4 h] | 20.1 | 02 | Civil | 4 | MB |
|  | 1 | **Mezzanine Level ( B05 . OTE AREA-4 ) Upper Part** |  |  | 2018-11-01 | 2018-11-13 |  |  |  |  |  |  |  |  |  |  |
| C1C1111F5S1040 |  | B05- AREA-4 Formwork |  | 6.25d | 2018-11-01 | 2018-11-06 | C1C1111F5S790 | 2d | 0d |  | Helper [686.4 h]; Carpenter [1029.6 h] | 120.63 | 02 | Civil | 4 | MB |
| C1C1111F5S1041 |  | B05-AREA-4 Rebar fixing |  | 6.25d | 2018-11-06 | 2018-11-11 | C1C1111F5S1040 SS+5d | 2d | 0d |  | Helper [500 h]; Steel Fixer [750 h] | 87.88 | 02 | Civil | 4 | MB |
| C1C1111F5S1042 |  | B05-AREA-4 Concrete Casting Slab |  | 2.5d | 2018-11-12 | 2018-11-13 | C1C1111F5S1041, LOE-SUM1-020 FF | 2d | 1.25d |  | Concrete Casting [19.38 CUM]; Helper [114.4 h]; Mason [171.6 h] | 20.1 | 02 | Civil | 4 | MB |
|  | 6 | **Technical Level (B-04 ) South ( AREA-4 to AREA-5 )** |  |  | 2018-11-11 | 2018-12-26 |  |  |  |  |  |  |  |  |  |  |
| LOE-SUM1-030 |  | South . P06 - Concrete Works | level of effort | 50d | 2018-11-11 | 2018-12-26 | C1C1111F5S800 SS | 1.5d | 0d | Saudi |  |  |  | Civil |  |  |
|  | 1 | **Technical Level (B-04 . AREA-4 , 1248 m3 )** |  |  | 2018-11-11 | 2018-12-16 |  |  |  |  |  |  |  |  |  |  |
| C1C1111F5S800 |  | B04- AREA-4 SE Formwork and Slab fixing |  | 8.75d | 2018-11-11 | 2018-11-18 | C1C1111F5S630, C1C1111F5S1042 FF+3.75d | 0.75d | 0d |  | Helper [343.2 h]; Carpenter [686.4 h] | 72.38 | 02 | Civil | 4 | MB |
| C1C1111F5S810 |  | B04 - AREA-4 Rebar fixing |  | 8.75d | 2018-11-15 | 2018-11-22 | C1C1111F5S800 SS+5d, B500 | 0.75d | 0d |  | Helper [343.2 h]; Steel Fixer [858 h] | 84.45 | 02 | Civil | 4 | MB |
| C1C1111F5S820 |  | B04- AREA-4 Technical Concrete Casting Slab |  | 2.5d | 2018-11-24 | 2018-11-25 | C1C1111F5S810 | 0.75d | 0d |  | Mason [572 h]; Helper [114.4 h]; Concrete Casting [402.49 CUM] | 48.25 | 02 | Civil | 4 | MB |
|  | 1 | **Technical Level (B-04 AREA-4 .Walls 5.15 ht ) 19 25** |  |  | 2018-11-26 | 2018-12-16 |  |  |  |  |  |  |  |  |  |  |
| C1C1111F5S830 |  | B04- AREA-4 Rebar fixing column / inner wall |  | 5d | 2018-11-26 | 2018-11-29 | C1C1111F5S820 | 8.25d | 0d |  | Steel Fixer [572 h]; Helper [228.8 h] | 56.29 | 03 | Civil | 4 | MB |
| C1C1111F5S840 |  | B04- AREA-4 Waterproofing wall (not by ZSCC) |  | 6.25d | 2018-11-26 | 2018-12-01 | C1C1111F5S820 | 0.75d | 0d |  |  |  | 03 | Civil | 4 | MB |
| C1C1111F5S850 |  | B04- AREA-4 Formwork fixing column / inner wall |  | 5d | 2018-12-01 | 2018-12-04 | C1C1111F5S830 | 8.25d | 1.25d |  | Carpenter [457.6 h]; Helper [286 h] | 52.28 | 03 | Civil | 4 | MB |
| C1C1111F5S860 |  | B04- AREA-4 Rebar fixing wall |  | 7.5d | 2018-12-02 | 2018-12-08 | C1C1111F5S840 | 0.75d | 0d |  | Steel Fixer [720 h]; Helper [457.6 h] | 82.79 | 03 | Civil | 4 | MB |
| C1C1111F5S870 |  | B04- AREA-4 Concrete Casting column / inner wall |  | 2.5d | 2018-12-06 | 2018-12-08 | C1C1111F5S850, C1C1111F5S860 FF | 7d | 6.25d |  | Mason [429 h]; Concrete Casting [254.03 CUM]; Helper [171.6 h] | 42.22 | 03 | Civil | 4 | MB |
| C1C1111F5S880 |  | B04- AREA-4 Formwork fixing wall |  | 7.5d | 2018-12-08 | 2018-12-13 | C1C1111F5S860 SS+6.25d | 0.75d | 0d |  | Carpenter [858 h]; Helper [343.2 h] | 84.45 | 03 | Civil | 4 | MB |
| C1C1111F5S890 |  | B04- AREA-4 Concrete Casting & Striking wall |  | 2.5d | 2018-12-15 | 2018-12-16 | C1C1111F5S870, C1C1111F5S880, CM020 FF | 0.75d | 0d |  | Mason [429 h]; Concrete Casting [269.66 CUM]; Helper [171.6 h] | 42.22 | 03 | Civil | 4 | MB |

| ID | WBS | Activity | Type | Duration | Start | Finish | Predecessors | Total float | Free float | Calendar | Resources | Cost | MILESTONE | Discipline | AREA | LOCATION |
| --- | --- | --- | --- | --- | --- | --- | --- | --- | --- | --- | --- | --- | --- | --- | --- | --- |
|  | 2 | **Technical Level (B-04 . AREA-5 , 823 m3 )** |  |  | 2018-11-24 | 2018-12-26 |  |  |  |  |  |  |  |  |  |  |
| C1C1111F5S900 |  | B04- AREA-5 Technical Formwork and Slab fixing |  | 8.75d | 2018-11-24 | 2018-12-01 | C1C1111F5S760 FF+7.5d, C1C1111F5S740 | 0d |  |  | Helper [343.2 h]; Carpenter [686.4 h] | 72.38 | 02 | Civil | 5 | MB |
| C1C1111F5S910 |  | B04-AREA-5 Technical Rebar fixing |  | 8.75d | 2018-11-29 | 2018-12-06 | C1C1111F5S900 FF+6.25d, B510 | 0d |  |  | Helper [343.2 h]; Steel Fixer [858 h] | 84.45 | 02 | Civil | 5 | MB |
| C1C1111F5S920 |  | B04-AREA-5 Technical Concrete Casting Slab |  | 2.5d | 2018-12-06 | 2018-12-08 | C1C1111F5S910 FF+1.25d | 0d |  |  | Mason [572 h]; Helper [114.4 h]; Concrete Casting [281.28 CUM] | 48.25 | 02 | Civil | 5 | MB |
|  | 1 | **Technical Level ( B04 AREA-5 .Walls 5.15 ht )** |  |  | 2018-12-09 | 2018-12-26 |  |  |  |  |  |  |  |  |  |  |
| C1C1111F5S930 |  | B04- AREA-5 Rebar fixing column |  | 5d | 2018-12-09 | 2018-12-12 | C1C1111F5S920 | 6.5d | 0d |  | Steel Fixer [572 h]; Helper [286 h] | 60.32 | 03 | Civil | 5 | MB |
| C1C1111F5S940 |  | B04- AREA-5 Waterproofing wall (not by ZSCC) |  | 7.5d | 2018-12-09 | 2018-12-15 | C1C1111F5S920 | 1.5d | 0d |  |  |  | 03 | Civil | 5 | MB |
| C1C1111F5S950 |  | B04- AREA-5 Formwork fixing column / inner wall |  | 5d | 2018-12-13 | 2018-12-17 | C1C1111F5S930, C1C1111F5S940 SS+2.5d | 6.5d | 0d |  | Helper [286 h]; Carpenter [457.6 h] | 52.28 | 03 | Civil | 5 | MB |
| C1C1111F5S960 |  | B04- AREA-5 Rebar fixing wall |  | 7.5d | 2018-12-15 | 2018-12-20 | C1C1111F5S940 FF+6.25d | 1.5d | 0d |  | Steel Fixer [900 h]; Helper [457.6 h] | 95.44 | 03 | Civil | 5 | MB |
| C1C1111F5S970 |  | B04- AREA-5 Concrete Casting column / inner wall |  | 2.5d | 2018-12-18 | 2018-12-19 | C1C1111F5S950 | 6.5d | 5d |  | Mason [429 h]; Concrete Casting [269.66 CUM]; Helper [171.6 h] | 42.22 | 03 | Civil | 5 | MB |
| C1C1111F5S980 |  | B04- AREA-5 Formwork fixing wall |  | 7.5d | 2018-12-19 | 2018-12-25 | C1C1111F5S960 SS+5d | 1.5d | 0d |  | Carpenter [900 h]; Helper [457.6 h] | 95.44 | 03 | Civil | 5 | MB |
| C1C1111F5S990 |  | B04- AREA-5 Concrete Casting & Striking wall |  | 2.5d | 2018-12-25 | 2018-12-26 | C1C1111F5S980 FF+1.25d, C1C1111F5S970, LOE-SUM1-030 FF | 1.5d | 0d |  | Mason [429 h]; Concrete Casting [357.37 CUM]; Helper [171.6 h] | 42.22 | 03 | Civil | 5 | MB |
|  | 7 | **Concourse Level B03 South ( AREA-4 to AREA-5 )** |  |  | 2018-12-17 | 2019-01-29 |  |  |  |  |  |  |  |  |  |  |
| LOE-SUM1-040 |  | South . P06 - Concrete Works | level of effort | 47.5d | 2018-12-17 | 2019-01-29 | C1C1111F5S1000 SS | 1.5d | 0d | Saudi |  |  |  | Civil |  |  |
|  | 1 | **Concourse Level ( B03 . AREA-4, 37.5 L , 616 m3 )** |  |  | 2018-12-17 | 2019-01-21 |  |  |  |  |  |  |  |  |  |  |
| C1C1111F5S1000 |  | B03- AREA-4 Formwork and Slab fixing |  | 7.5d | 2018-12-17 | 2018-12-23 | C1C1111F5S890 | 0.75d | 0d |  | Helper [343.2 h]; Carpenter [686.4 h] | 72.38 | 03 | Civil | 4 | MB |
| C1C1111F5S1020 |  | B03- AREA-4 Rebar fixing |  | 6.25d | 2018-12-24 | 2018-12-29 | C1C1111F5S1000, B550 FS+32.5d | 0.75d | 0d |  | Helper [343.2 h]; Steel Fixer [715 h] | 74.39 | 03 | Civil | 4 | MB |
| C1C1111F5S1045 |  | B03- AREA-4 Concrete Casting Slab |  | 2.5d | 2018-12-30 | 2018-12-31 | C1C1111F5S1020 | 0.75d | 0d |  | Concrete Casting [584.27 CUM]; Mason [572 h]; Helper [143 h] | 50.26 | 03 | Civil | 4 | MB |
| C1C1111F5S1055 |  | B03- AREA-4 Waterproofing wall (not by ZSCC) |  | 7.5d | 2019-01-01 | 2019-01-07 | C1C1111F5S1045 | 0.75d | 0d |  |  |  | 03 | Civil | 4 | MB |
| C1C1111F5S1060 |  | B03- AREA-4 Rebar fixing wall / column / staircase |  | 7.5d | 2019-01-08 | 2019-01-14 | C1C1111F5S1055 | 0.75d | 0d |  | Helper [457.6 h]; Steel Fixer [900 h] | 95.44 | 03 | Civil | 4 | MB |
| C1C1111F5S1070 |  | B03- AREA-4 Formwork fixing wall / column / staircase |  | 7.5d | 2019-01-13 | 2019-01-19 | C1C1111F5S1060 SS+5d | 0.75d | 0d |  | Helper [457.6 h]; Carpenter [900 h] | 95.44 | 03 | Civil | 4 | MB |
| C1C1111F5S1080 |  | B03- AREA-4 Concrete Casting wall / column / staircase |  | 2.5d | 2019-01-20 | 2019-01-21 | C1C1111F5S1070 | 0.75d | 0d |  | Concrete Casting [355.22 CUM]; Helper [143 h]; Mason [429 h] | 40.21 | 03 | Civil | 4 | MB |
|  | 2 | **Concourse Level ( B03 . AREA-5, 24 L , 475 m3 )** |  |  | 2018-12-27 | 2019-01-29 |  |  |  |  |  |  |  |  |  |  |
| C1C1111F5S1090 |  | B03- AREA-5 Formwork and Slab fixing |  | 7.5d | 2018-12-27 | 2019-01-02 | C1C1111F5S990 | 1.5d | 0d |  | Helper [357.5 h]; Carpenter [686.4 h] | 73.38 | 03 | Civil | 5 | MB |
| C1C1111F5S1210 |  | B03- AREA-5 Rebar fixing |  | 7.5d | 2019-01-02 | 2019-01-08 | B560 FS+32.5d, C1C1111F5S1090 SS+6.25d | 1.5d | 0d |  | Helper [343.2 h]; Steel Fixer [858 h] | 84.45 | 03 | Civil | 5 | MB |
| C1C1111F5S1230 |  | B03- AREA-5 Concrete Casting Slab |  | 2.5d | 2019-01-09 | 2019-01-10 | C1C1111F5S1210 | 1.5d | 0d |  | Concrete Casting [266.46 CUM]; Helper [143 h]; Mason [572 h] | 50.26 | 03 | Civil | 5 | MB |
| C1C1111F5S1245 |  | B03- AREA-5 Waterproofing wall (not by ZSCC) |  | 7.5d | 2019-01-12 | 2019-01-17 | C1C1111F5S1230 | 1.5d | 0d |  |  |  | 03 | Civil | 5 | MB |
| C1C1111F5S1250 |  | B03- AREA-5 Rebar fixing column / wall / staircase |  | 7.5d | 2019-01-17 | 2019-01-23 | C1C1111F5S1245 FF+6.25d | 1.5d | 0d |  | Helper [400.4 h]; Steel Fixer [858 h] | 88.47 | 03 | Civil | 5 | MB |
| C1C1111F5S1260 |  | B03- AREA-5 Formwork fixing column / wall / staircase |  | 7.5d | 2019-01-21 | 2019-01-27 | C1C1111F5S1250 SS+3.75d | 1.5d | 0d |  | Helper [343.2 h]; Carpenter [858 h] | 84.45 | 03 | Civil | 5 | MB |
| C1C1111F5S1270 |  | B03- AREA-5 Concrete Casting column / wall / staircase |  | 2.5d | 2019-01-28 | 2019-01-29 | C1C1111F5S1260, CM070 FF, LOE-SUM1-040 FF | 1.5d | 0d |  | Concrete Casting [527.44 CUM]; Helper [143 h]; Mason [429 h] | 40.21 | 03 | Civil | 5 | MB |

| ID | WBS | Activity | Type | Duration | Start | Finish | Predecessors | Total float | Free float | Calendar | Resources | Cost | Discipline | MILESTONE | AREA | LOCATION |
| --- | --- | --- | --- | --- | --- | --- | --- | --- | --- | --- | --- | --- | --- | --- | --- | --- |
|  | 8 | **TV Louver Level B02 South ( AREA-4 to AREA-5 )** |  |  | 2019-01-22 | 2019-03-11 |  |  |  |  |  |  |  |  |  |  |
| LOE-SUM1-050 |  | South . P06 - Concrete Works | level of effort | 52.5d | 2019-01-22 | 2019-03-11 | C1C1111F5S1280 SS | 0.75d | 0d | Saudi |  |  | Civil |  |  |  |
|  | 1 | **TV Louver Level ( B02 . AREA-4, 37.5 L , 616 m3 )** |  |  | 2019-01-22 | 2019-02-25 |  |  |  |  |  |  |  |  |  |  |
| C1C1111F5S1280 |  | B02- AREA-4 Formwork and Slab fixing |  | 6.25d | 2019-01-22 | 2019-01-27 | C1C1111F5S1080 | 0.75d | 0d |  | Helper [343.2 h]; Carpenter [686.4 h] | 72.38 | Civil | 03 | 4 | MB |
| C1C1111F5S1300 |  | B02- AREA-4 Rebar fixing |  | 6.25d | 2019-01-28 | 2019-02-02 | B600 FS+32.5d, C1C1111F5S1280 | 0.75d | 0d |  | Helper [343.2 h]; Steel Fixer [715 h] | 74.39 | Civil | 03 | 4 | MB |
| C1C1111F5S1320 |  | B02- AREA-4 Concrete Casting Slab |  | 2.5d | 2019-02-03 | 2019-02-04 | C1C1111F5S1300 | 0.75d | 0d |  | Concrete Casting [9.69 CUM]; Helper [143 h]; Mason [572 h] | 50.26 | Civil | 03 | 4 | MB |
| C1C1111F5S1340 |  | B02- AREA-4 Waterproofing wall (not by ZSCC) |  | 7.5d | 2019-02-05 | 2019-02-11 | C1C1111F5S1320 | 18.75d | 0d |  |  |  | Civil | 03 | 4 | MB |
| C1C1111F5S1350 |  | B02- AREA-4 Rebar fixing wall / column / staircase |  | 7.5d | 2019-02-12 | 2019-02-18 | C1C1111F5S1320, C1C1111F5S1340 | 18.75d | 0d |  | Helper [457.6 h]; Steel Fixer [900 h] | 95.44 | Civil | 03 | 4 | MB |
| C1C1111F5S1360 |  | B02- AREA-4 Formwork fixing wall / column / staircase |  | 7.5d | 2019-02-17 | 2019-02-23 | C1C1111F5S1350 SS+5d | 18.75d | 0d |  | Helper [457.6 h]; Carpenter [900 h] | 95.44 | Civil | 03 | 4 | MB |
| C1C1111F5S1370 |  | B02- AREA-4 Concrete Casting wall / column / staircase |  | 2.5d | 2019-02-24 | 2019-02-25 | C1C1111F5S1360 | 18.75d | 0d |  | Concrete Casting [271.92 CUM]; Helper [143 h]; Mason [429 h] | 40.21 | Civil | 03 | 4 | MB |
|  | 2 | **TV Louver Level ( B02 . AREA-5, 24 L , 475 m3 )** |  |  | 2019-02-05 | 2019-03-11 |  |  |  |  |  |  |  |  |  |  |
| C1C1111F5S1380 |  | B02- AREA-5 Formwork and Slab fixing |  | 7.5d | 2019-02-05 | 2019-02-11 | C1C1111F5S1270, C1C1111F5S1320 | 0.75d | 0d |  | Helper [357.5 h]; Carpenter [686.4 h] | 73.38 | Civil | 03 | 5 | MB |
| C1C1111F5S1400 |  | B02- AREA-5 Rebar fixing |  | 7.5d | 2019-02-11 | 2019-02-17 | C1C1111F5S1380 SS+6.25d, B610 FS+32.5d | 0.75d | 0d |  | Helper [343.2 h]; Steel Fixer [858 h] | 84.45 | Civil | 03 | 5 | MB |
| C1C1111F5S1420 |  | B02- AREA-5 Concrete Casting Slab |  | 2.5d | 2019-02-18 | 2019-02-19 | C1C1111F5S1400 | 0.75d | 0d |  | Concrete Casting [107.48 CUM]; Helper [143 h]; Mason [572 h] | 50.26 | Civil | 03 | 5 | MB |
| C1C1111F5S1440 |  | B02- AREA-5 Waterproofing wall (not by ZSCC) |  | 7.5d | 2019-02-20 | 2019-02-26 | C1C1111F5S1420 | 0.75d | 0d |  |  |  | Civil | 03 | 5 | MB |
| C1C1111F5S1450 |  | B02- AREA-5 Rebar fixing column / wall / staircase |  | 7.5d | 2019-02-27 | 2019-03-05 | C1C1111F5S1440 | 0.75d | 0d |  | Helper [343.2 h]; Steel Fixer [686.4 h] | 72.38 | Civil | 03 | 5 | MB |
| C1C1111F5S1460 |  | B02- AREA-5 Formwork fixing column / wall / staircase |  | 7.5d | 2019-03-03 | 2019-03-09 | C1C1111F5S1450 FF+3.75d | 0.75d | 0d |  | Helper [343.2 h]; Carpenter [686.4 h] | 72.38 | Civil | 03 | 5 | MB |
| C1C1111F5S1470 |  | B02- AREA-5 Concrete Casting column / wall / staircase |  | 2.5d | 2019-03-10 | 2019-03-11 | C1C1111F5S1460, LOE-SUM1-050 FF | 0.75d | 0d |  | Concrete Casting [364.15 CUM]; Helper [143 h]; Mason [429 h] | 40.21 | Civil | 03 | 5 | MB |
|  | 9 | **Top Slab Level B01 South ( AREA-4 to AREA-5 )** |  |  | 2019-02-27 | 2019-04-02 |  |  |  |  |  |  |  |  |  |  |
| LOE-SUM1-055 |  | South . P06 - Concrete Works | level of effort | 37.5d | 2019-02-27 | 2019-04-02 | C1C1111F5S1480 SS | 6.25d | 0d | Saudi |  |  | Civil |  |  |  |
|  | 1 | **Top Slab Level ( B01 . AREA-4, 37.5 L , 616 m3 )** |  |  | 2019-02-27 | 2019-03-19 |  |  |  |  |  |  |  |  |  |  |
| C1C1111F5S1480 |  | B01- AREA-4 Formwork and Slab fixing |  | 10d | 2019-02-27 | 2019-03-07 | C1C1111F5S1370 FS+1.25d | 18.75d | 0d |  | Helper [343.2 h]; Carpenter [686.4 h] | 72.38 | Civil | 03 | 4 | MB |
| C1C1111F5S1500 |  | B01- AREA-4 Rebar fixing |  | 10d | 2019-03-09 | 2019-03-17 | C1C1111F5S1480, B650 FS+32.5d, C1C1111F5S1480 SS+5d | 18.75d | 0d |  | Helper [343.2 h]; Steel Fixer [715 h] | 74.39 | Civil | 03 | 4 | MB |
| C1C1111F5S1520 |  | B01- AREA-4 Concrete Casting Slab |  | 2.5d | 2019-03-18 | 2019-03-19 | C1C1111F5S1500, C1C1111F5S1480 SS | 18.75d | 0d |  | Concrete Casting [450.59 CUM]; Helper [143 h]; Mason [572 h] | 50.26 | Civil | 03 | 4 | MB |

| ID | WBS | Activity | Type | Duration | Start | Finish | Predecessors | Total float | Free float | Calendar | Resources | Cost | MILESTONE | Discipline | AREA | LOCATION |
| --- | --- | --- | --- | --- | --- | --- | --- | --- | --- | --- | --- | --- | --- | --- | --- | --- |
|  | 10 | **Top Slab Level ( B01 . AREA-5 )** |  |  | 2019-03-13 | 2019-04-02 |  |  |  |  |  |  |  |  |  |  |
| C1C1111F5S1570 |  | B01- AREA-5 Formwork and Slab fixing |  | 10d | 2019-03-13 | 2019-03-21 | C1C1111F5S1470 FS+1.25d | 0.75d | 0d |  | Helper [357.5 h]; Carpenter [686.4 h] | 73.38 | 03 | Civil | 5 | MB |
| C1C1111F5S1590 |  | B01- AREA-5 Rebar fixing |  | 10d | 2019-03-23 | 2019-03-31 | B660 FS+32.5d, C1C1111F5S1570 | 6.25d | 0d |  | Helper [343.2 h]; Steel Fixer [686.4 h] | 72.38 | 03 | Civil | 5 | MB |
| C1C1111F5S1610 |  | B01- AREA-5 Concrete Casting Slab |  | 2.5d | 2019-04-01 | 2019-04-02 | C1C1111F5S1590, C1C1111F5S1520, C1C1111F5S1520 FF, LOE-SUM1-055 FF | 6.25d | 0d |  | Concrete Casting [773.94 CUM]; Helper [143 h]; Mason [572 h] | 50.26 | 03 | Civil | 5 | MB |
|  | 10 | **Paraphet Wall above Top Slab South ( B01 . AREA-4 & 5 )** |  |  | 2019-03-20 | 2019-05-06 |  |  |  |  |  |  |  |  |  |  |
| LOE-SUM1-060 |  | South . P06 - Concrete Works | level of effort | 51.25d | 2019-03-20 | 2019-05-06 | C1C1111F5S1690 SS | 53.25d | 0d | Saudi |  |  |  | Civil |  |  |
|  | 1 | **Paraphet Wall above Top Slab ( B01 . AREA-4)** |  |  | 2019-03-20 | 2019-04-21 |  |  |  |  |  |  |  |  |  |  |
| C1C1111F5S1690 |  | B01- AREA-4 Rebar fixing column / wall / staircase |  | 7.5d | 2019-03-20 | 2019-03-26 | C1C1111F5S1520 | 58.25d | 0d |  | Helper [400.4 h]; Steel Fixer [686.4 h] | 76.4 |  | Civil | 4 | MB |
| C1C1111F5S1700 |  | B01- AREA-4 Formwork fixing column / wall/ staircase |  | 7.5d | 2019-03-27 | 2019-04-02 | C1C1111F5S1690 | 58.25d | 0d |  | Helper [343.2 h]; Carpenter [686.4 h] | 72.38 |  | Civil | 4 | MB |
| C1C1111F5S1710 |  | B01- AREA-4 Concrete Casting column / wall / staircase |  | 2.5d | 2019-04-03 | 2019-04-04 | C1C1111F5S1700 | 58.25d | 0d |  | Concrete Casting [215.28 CUM]; Helper [143 h]; Mason [429 h] | 40.21 |  | Civil | 4 | MB |
| C1C1111F5S1720 |  | B01- AREA-4 Waterproofing slab/ wall (not by ZSCC) |  | 6.25d | 2019-04-06 | 2019-04-10 | C1C1111F5S1710 | 58.25d | 0d |  |  |  |  | Civil | 4 | MB |
| C1C1111F5S1722 |  | B01- AREA-4 Screed |  | 3.75d | 2019-04-11 | 2019-04-14 | C1C1111F5S1720 | 58.25d | 0d |  | Helper [171.6 h]; Mason [257.4 h] | 30.16 |  | Civil | 4 | MB |
| C1C1111F5S1725 |  | B01- AREA-4 Backfilling & compaction (Optional) |  | 7.5d | 2019-04-15 | 2019-04-21 | C1C1111F5S1722 | 58.25d | 8.75d |  | Helper [514.8 h] | 36.19 |  | Civil | 4 | MB |
|  | 2 | **Paraphet Wall above Top Slab ( B01 . AREA-5)** |  |  | 2019-04-03 | 2019-05-06 |  |  |  |  |  |  |  |  |  |  |
| C1C1111F5S1730 |  | B01- AREA-5 Rebar fixing column / wall / staircase |  | 7.5d | 2019-04-03 | 2019-04-09 | C1C1111F5S1610, C1C1111F5S1820 FF | 49.5d | 0d |  | Helper [400.4 h]; Steel Fixer [858 h] | 88.47 |  | Civil | 5 | MB |
| C1C1111F5S1740 |  | B01- AREA-5 Formwork fixing column / wall/ staircase |  | 7.5d | 2019-04-10 | 2019-04-16 | C1C1111F5S1730 | 49.5d | 0d |  | Helper [343.2 h]; Carpenter [858 h] | 84.45 |  | Civil | 5 | MB |
| C1C1111F5S1750 |  | B01- AREA-5 Concrete Casting column / wall / staircase |  | 2.5d | 2019-04-17 | 2019-04-18 | C1C1111F5S1810 FF, C1C1111F5S1740, C1C1111F5S1800 FF, CM030 FF | 49.5d | 0d |  | Concrete Casting [215.28 CUM]; Helper [143 h]; Mason [429 h] | 40.21 |  | Civil | 5 | MB |
| C1C1111F5S1760 |  | B01- AREA-4 Waterproofing slab/ wall (not by ZSCC) |  | 7.5d | 2019-04-20 | 2019-04-25 | C1C1111F5S1750 | 49.5d | 0d |  |  |  |  | Civil | 4 | MB |
| C1C1111F5S1770 |  | B01- AREA-4 Protection Screed |  | 3.75d | 2019-04-27 | 2019-04-29 | C1C1111F5S1760 | 49.5d | 0d |  | Helper [171.6 h]; Mason [257.4 h] | 30.16 |  | Civil | 4 | MB |
| C1C1111F5S1780 |  | B01- AREA-4 Backfilling & compaction (Optional) |  | 7.5d | 2019-04-30 | 2019-05-06 | C1C1111F5S1770, C1C1111F5S1725, LOE-SUM1-060 FF | 49.5d | 50d |  | Helper [514.8 h] | 36.19 |  | Civil | 4 | MB |
|  | 11 | **LOE Commodities Civil - South ( B01 to B07)** |  |  | 2018-09-01 | 2019-04-18 |  |  |  |  |  |  |  |  |  |  |
| C1C1111F5S1810 |  | LOE - South B07 to B01 - Formworks | level of effort | 247.5d | 2018-09-01 | 2019-04-18 | C1C1111F5S330 SS | 49.5d | 0d |  | Formworks [16980 Square Meter] |  |  | Civil |  | MB |
| C1C1111F5S1820 |  | LOE - South B07 to B01 - Rebar | level of effort | 230d | 2018-09-08 | 2019-04-09 | C1C1111F5S350 SS | 49.5d | 0d |  | Steel Reinforcement [1641.14 tons] |  |  | Civil |  | MB |
| C1C1111F5S1800 |  | LOE - Mass concrete infill between pemanent wall and SOE | level of effort | 233.75d | 2018-09-13 | 2019-04-18 | C1C1111F5S370 SS | 49.5d | 0d |  | Concrete infill [1621 CUM] |  |  | Civil |  | MB |

| ID | WBS | Activity | Type | Duration | Start | Finish | Predecessors | Total float | Free float | Constraint | Calendar | Resources | Cost | Discipline | LOCATION | MILESTONE |
| --- | --- | --- | --- | --- | --- | --- | --- | --- | --- | --- | --- | --- | --- | --- | --- | --- |
|  | 2 | **CENTRAL MAIN BOX Concrete Works (Zone 7 to Zone 5)** |  |  | 2018-09-03 | 2019-06-15 |  |  |  |  |  |  |  |  |  |  |
|  | 1 | **Base Raft - (Zone 7 to Zone 5)** |  |  | 2018-09-03 | 2018-11-18 |  |  |  |  |  |  |  |  |  |  |
| LOE-SUM1-070 |  | Central . B07 - Concrete Works | level of effort | 82.5d | 2018-09-03 | 2018-11-18 | C1C1111F5C340 SS | 0d |  |  | Saudi |  |  | Civil |  |  |
|  | 1 | **Base Raft - Zone 7 (25.05 x 13.3 , 1007 m3)** |  |  | 2018-09-03 | 2018-09-04 |  |  |  |  |  |  |  |  |  |  |
| C1C1111F5C340 |  | Base raft Zone-7 Concrete Casting base raft |  | 2.5d | 2018-09-03 | 2018-09-04 | MOB1F5030 SS+2.5d | 0d |  | finish on 2018-09-04 |  | Mason [429 h]; Concrete Casting [905.52 CUM]; Helper [171.6 h] | 42.22 | Civil | MB |  |
|  | 2 | **Base Raft - Zone 6 (25.05 x 13.09 , 958 m3)** |  |  | 2018-09-05 | 2018-09-25 |  |  |  |  |  |  |  |  |  |  |
| C1C1111F5C350 |  | Base raft Zone-6 Waterproofing Wall (not by ZSCC), Base raft & Blindiing |  | 6.25d | 2018-09-05 | 2018-09-10 | C1C1111F5C340 | 0d |  | finish on 2018-09-10 |  |  |  | Civil | MB |  |
| C1C1111F5C360 |  | Base raft Zone-6 Rebar fixing |  | 8.75d | 2018-09-11 | 2018-09-18 | C1C1111F5C350 | 0d |  |  |  | Helper [500.5 h]; Steel Fixer [840 h] | 94.24 | Civil | MB |  |
| C1C1111F5C370 |  | Base raft Zone-6 Formwork fixing |  | 5d | 2018-09-19 | 2018-09-23 | C1C1111F5C360 | 0d |  |  |  | Helper [257.4 h]; Carpenter [457.6 h] | 50.27 | Civil | MB |  |
| C1C1111F5C380 |  | Base raft Zone-6 Concrete Casting base raft |  | 2.5d | 2018-09-24 | 2018-09-25 | C1C1111F5C370 | 0d |  | finish on 2018-09-25 |  | Mason [429 h]; Helper [171.6 h]; Concrete Casting [969.53 CUM] | 42.22 | Civil | MB |  |
|  | 3 | **Base Raft - Zone 5 (25.05 x 12.65 , 925 m3)** |  |  | 2018-09-16 | 2018-10-09 |  |  |  |  |  |  |  |  |  |  |
| C1C1111F5C390 |  | Base raft Zone-5 Waterproofing Wall (not by ZSCC), Base raft & Blindiing |  | 7.5d | 2018-09-16 | 2018-09-22 | C1C1111F5C350 | -0.5d | 0d | finish on or after 2018-09-22 |  |  |  | Civil | MB | 09 |
| C1C1111F5C400 |  | Base raft Zone-5 Rebar fixing |  | 10d | 2018-09-23 | 2018-10-01 | C1C1111F5C390 | -0.5d | 0d |  |  | Helper [514.8 h]; Steel Fixer [960 h] | 103.68 | Civil | MB | 09 |
| C1C1111F5C410 |  | Base raft Zone-5 Formwork fixing |  | 6.25d | 2018-10-02 | 2018-10-07 | C1C1111F5C400 | -0.5d | 0d |  |  | Helper [214.5 h]; Carpenter [429 h] | 45.24 | Civil | MB | 09 |
| C1C1111F5C420 |  | Base raft Zone-5 Concrete Casting base raft |  | 2.5d | 2018-10-08 | 2018-10-09 | C1C1111F5C410, LOE-SUM1-070 FF | -0.5d | 0d |  |  | Mason [429 h]; Concrete Casting [783.63 CUM]; Helper [114.4 h] | 38.2 | Civil | MB | 09 |
|  | 2 | **Outer & Inner Wall -Zone 7 to Zone 5- ( Base Raft to Mezzanine Floor)** |  |  | 2018-09-16 | 2018-11-06 |  |  |  |  |  |  |  |  |  |  |
|  | 1 | **Outer & Inner Wall Zone 7** |  |  | 2018-09-16 | 2018-10-16 |  |  |  |  |  |  |  |  |  |  |
| C1C1111F5C430 |  | Base raft Zone-7 Waterproofing Wall (not by ZSCC) |  | 5d | 2018-09-16 | 2018-09-19 | C1C1111F5C340, C1C1111F5C390 SS | 14.5d | 0d | finish on or after 2018-09-19 |  |  |  | Civil | MB | 10 |
| C1C1111F5C440 |  | Base raft Zone-7 West Rebar fixing wall |  | 5d | 2018-09-20 | 2018-09-24 | C1C1111F5C450 SS | 14.5d | 5d |  |  | Helper [171.6 h]; Steel Fixer [572 h] | 52.27 | Civil | MB | 10 |
| C1C1111F5C450 |  | Base raft Zone-7 East Rebar fixing wall |  | 5d | 2018-09-20 | 2018-09-24 | C1C1111F5C430, C1C1111F5C340 | 14.5d | 0d |  |  | Helper [171.6 h]; Steel Fixer [572 h] | 52.27 | Civil | MB | 10 |
| C1C1111F5C460 |  | Base raft Zone-7 Rebar fixing column |  | 5d | 2018-09-25 | 2018-09-29 | C1C1111F5C450 | 17d | 0d |  |  | Helper [171.6 h]; Steel Fixer [572 h] | 52.27 | Civil | MB | 10 |
| C1C1111F5C470 |  | Base raft Zone-7 East Formwork fixing wall (1st Lift ) |  | 5d | 2018-09-25 | 2018-09-29 | C1C1111F5C460 SS | 17d | 0d |  |  | Helper [228.8 h]; Carpenter [572 h] | 56.29 | Civil | MB | 10 |
| C1C1111F5C480 |  | Base raft Zone-7 West Formwork fixing wall ( 1st Lift ) |  | 5d | 2018-09-30 | 2018-10-03 | C1C1111F5C440, C1C1111F5C470 | 17d | 0d |  |  | Helper [228.8 h]; Carpenter [572 h] | 56.29 | Civil | MB | 10 |
| C1C1111F5C490 |  | Base raft Zone-7 East Concrete Casting & Striking wall ( 1st Lift ) |  | 2.5d | 2018-10-02 | 2018-10-03 | C1C1111F5C480 FF, C1C1111F5C470 | 17d | 0d |  |  | Mason [429 h]; Concrete Casting [53.82 CUM]; Helper [85.8 h] | 36.19 | Civil | MB | 10 |
| C1C1111F5C500 |  | Base raft Zone-7 East Formwork fixing wall (2nd Lift) |  | 6.25d | 2018-10-04 | 2018-10-09 | C1C1111F5C490 | 17d | 0d |  |  | Helper [286 h]; Carpenter [715 h] | 70.37 | Civil | MB | 11 |
| C1C1111F5C520 |  | Base raft Zone-7 West Concrete Casting & Striking wall (1st Lift ) |  | 2.5d | 2018-10-04 | 2018-10-06 | C1C1111F5C480 | 22d | 0d |  |  | Mason [429 h]; Concrete Casting [53.82 CUM]; Helper [85.8 h] | 36.19 | Civil | MB | 10 |
| C1C1111F5C510 |  | Base raft Zone-7 Formwork fixing column / inner wall |  | 3.75d | 2018-10-07 | 2018-10-09 | C1C1111F5C500 FF | 17d | 0d |  |  | Helper [128.7 h]; Carpenter [429 h] | 39.21 | Civil | MB | 11 |
| C1C1111F5C530 |  | Base raft Zone-7 West Formwork fixing wall (2nd Lift) |  | 3.75d | 2018-10-07 | 2018-10-09 | C1C1111F5C510 FF, C1C1111F5C520 | 22d | 5d |  |  | Helper [171.6 h]; Carpenter [429 h] | 42.22 | Civil | MB | 11 |
| C1C1111F5C540 |  | Base raft Zone-7 Concrete Casting column / inner wall |  | 2.5d | 2018-10-10 | 2018-10-11 | C1C1111F5C510 | 17d | 0d |  |  | Concrete Casting [29.06 CUM]; Helper [143 h]; Mason [429 h] | 40.21 | Civil | MB | 11 |
| C1C1111F5C550 |  | Base raft Zone-7 East Concrete Casting & Striking wall (2nd Lift) |  | 2.5d | 2018-10-13 | 2018-10-14 | C1C1111F5C540, C1C1111F5C500 | 17d | 0d |  |  | Concrete Casting [107.64 CUM]; Helper [143 h]; Mason [429 h] | 40.21 | Civil | MB | 11 |
| C1C1111F5C560 |  | Base raft Zone-7 West Concrete Casting & Striking wall (2nd Lift) |  | 2.5d | 2018-10-15 | 2018-10-16 | C1C1111F5C550, C1C1111F5C530 | 17d | 17.5d |  |  | Concrete Casting [107.64 CUM]; Helper [143 h]; Mason [429 h] | 40.21 | Civil | MB | 11 |

| ID | WBS | Activity | Duration | Start | Finish | Predecessors | Total float | Free float | Resources | Cost | MILESTONE | Discipline | LOCATION |
| --- | --- | --- | --- | --- | --- | --- | --- | --- | --- | --- | --- | --- | --- |
|  | 2 | **Outer & Inner Wall Zone 6** |  | 2018-09-26 | 2018-10-27 |  |  |  |  |  |  |  |  |
| C1C1111F5C570 |  | Base raft Zone-6 Waterproofing Wall (not by ZSCC) | 5d | 2018-09-26 | 2018-09-30 | C1C1111F5C380 | 8.25d | 0d |  |  | 10 | Civil | MB |
| C1C1111F5C580 |  | Base raft Zone-6 West Rebar fixing wall | 5d | 2018-10-01 | 2018-10-04 | C1C1111F5C380, C1C1111F5C440, C1C1111F5C570 | 8.25d | 0d | Helper [171.6 h]; Steel Fixer [572 h] | 52.27 | 10 | Civil | MB |
| C1C1111F5C590 |  | Base raft Zone-6 East Rebar fixing wall | 5d | 2018-10-01 | 2018-10-04 | C1C1111F5C580 SS | 8.25d | 0d | Helper [171.6 h]; Steel Fixer [572 h] | 52.27 | 10 | Civil | MB |
| C1C1111F5C600 |  | Base raft Zone-6 Rebar fixing column / inner wall | 5d | 2018-10-06 | 2018-10-09 | C1C1111F5C590 | 8.25d | 0d | Helper [171.6 h]; Steel Fixer [572 h] | 52.27 | 10 | Civil | MB |
| C1C1111F5C610 |  | Base raft Zone-6 East Formwork fixing wall (1st Lift ) | 5d | 2018-10-06 | 2018-10-09 | C1C1111F5C600 SS | 8.25d | 0d | Helper [228.8 h]; Carpenter [572 h] | 56.29 | 10 | Civil | MB |
| C1C1111F5C620 |  | Base raft Zone-6 West Formwork fixing wall ( 1st Lift ) | 5d | 2018-10-10 | 2018-10-14 | C1C1111F5C610 | 8.25d | 0d | Helper [228.8 h]; Carpenter [572 h] | 56.29 | 10 | Civil | MB |
| C1C1111F5C630 |  | Base raft Zone-6 East Concrete Casting & Striking wall ( 1st Lift ) | 2.5d | 2018-10-13 | 2018-10-14 | C1C1111F5C610, C1C1111F5C620 FF | 8.25d | 0d | Mason [429 h]; Concrete Casting [49.52 CUM]; Helper [143 h] | 40.21 | 10 | Civil | MB |
| C1C1111F5C640 |  | Base raft Zone-6 East Formwork fixing wall (2nd Lift) | 6.25d | 2018-10-15 | 2018-10-20 | C1C1111F5C630 | 8.25d | 0d | Helper [286 h]; Carpenter [715 h] | 70.37 | 11 | Civil | MB |
| C1C1111F5C660 |  | Base raft Zone-6 West Concrete Casting & Striking wall (1st Lift ) | 2.5d | 2018-10-15 | 2018-10-16 | C1C1111F5C620 | 13.25d | 3.75d | Mason [429 h]; Concrete Casting [49.52 CUM]; Helper [143 h] | 40.21 | 10 | Civil | MB |
| C1C1111F5C650 |  | Base raft Zone-6 Formwork fixing column / inner wall | 3.75d | 2018-10-17 | 2018-10-20 | C1C1111F5C640 FF | 8.25d | 0d | Helper [128.7 h]; Carpenter [429 h] | 39.21 | 11 | Civil | MB |
| C1C1111F5C670 |  | Base raft Zone-6 West Formwork fixing wall (2nd Lift) | 3.75d | 2018-10-21 | 2018-10-23 | C1C1111F5C660, C1C1111F5C650 | 9.5d | 1.25d | Helper [171.6 h]; Carpenter [429 h] | 42.22 | 11 | Civil | MB |
| C1C1111F5C680 |  | Base raft Zone-6 Concrete Casting column / inner wall | 2.5d | 2018-10-21 | 2018-10-22 | C1C1111F5C650 | 8.25d | 0d | Concrete Casting [30.52 CUM]; Helper [143 h]; Mason [429 h] | 40.21 | 11 | Civil | MB |
| C1C1111F5C690 |  | Base raft Zone-6 East Concrete Casting & Striking wall (2nd Lift) | 2.5d | 2018-10-23 | 2018-10-24 | C1C1111F5C640, C1C1111F5C680 | 8.25d | 0d | Concrete Casting [99.03 CUM]; Helper [143 h]; Mason [429 h] | 40.21 | 11 | Civil | MB |
| C1C1111F5C700 |  | Base raft Zone-6 West Concrete Casting & Striking wall (2nd Lift) | 2.5d | 2018-10-25 | 2018-10-27 | C1C1111F5C690, C1C1111F5C670 | 8.25d | 8.75d | Concrete Casting [99.03 CUM]; Helper [143 h]; Mason [429 h] | 40.21 | 11 | Civil | MB |
|  | 3 | **Outer & Inner Wall Zone 5** |  | 2018-10-10 | 2018-11-06 |  |  |  |  |  |  |  |  |
| C1C1111F5C710 |  | Base raft Zone-5 Waterproofing Wall (not by ZSCC) | 5d | 2018-10-10 | 2018-10-14 | C1C1111F5C420 | -0.5d | 0d |  |  | 10 | Civil | MB |
| C1C1111F5C720 |  | Base raft Zone-5 West Rebar fixing wall | 5d | 2018-10-15 | 2018-10-18 | C1C1111F5C580, C1C1111F5C420, C1C1111F5C710 | -0.5d | 0d | Helper [171.6 h]; Steel Fixer [572 h] | 52.27 | 10 | Civil | MB |
| C1C1111F5C730 |  | Base raft Zone-5 East Rebar fixing wall | 5d | 2018-10-15 | 2018-10-18 | C1C1111F5C720 SS | -0.5d | 0d | Helper [171.6 h]; Steel Fixer [572 h] | 52.27 | 10 | Civil | MB |
| C1C1111F5C735 |  | Base raft Zone-5 Rebar fixing column / inner wall | 5d | 2018-10-20 | 2018-10-23 | C1C1111F5C730 | -0.5d | 0d | Helper [171.6 h]; Steel Fixer [572 h] | 52.27 | 10 | Civil | MB |
| C1C1111F5C740 |  | Base raft Zone-5 East Formwork fixing wall (1st Lift ) | 5d | 2018-10-20 | 2018-10-23 | C1C1111F5C735 SS | -0.5d | 0d | Helper [228.8 h]; Carpenter [572 h] | 56.29 | 10 | Civil | MB |
| C1C1111F5C750 |  | Base raft Zone-5 West Formwork fixing wall ( 1st Lift ) | 5d | 2018-10-22 | 2018-10-25 | C1C1111F5C740 SS+2.5d | -0.5d | 0d | Helper [228.8 h]; Carpenter [572 h] | 56.29 | 10 | Civil | MB |
| C1C1111F5C760 |  | Base raft Zone-5 East Concrete Casting & Striking wall ( 1st Lift ) | 2.5d | 2018-10-24 | 2018-10-25 | C1C1111F5C740, C1C1111F5C750 FF | -0.5d | 0d | Mason [429 h]; Concrete Casting [41.98 CUM]; Helper [143 h] | 40.21 | 10 | Civil | MB |
| C1C1111F5C770 |  | Base raft Zone-5 West Concrete Casting & Striking wall (1st Lift ) | 2.5d | 2018-10-27 | 2018-10-28 | C1C1111F5C750 | 3.25d | 3.75d | Mason [429 h]; Concrete Casting [41.98 CUM]; Helper [143 h] | 40.21 | 10 | Civil | MB |
| C1C1111F5C780 |  | Base raft Zone-5 East Formwork fixing wall (2nd Lift) | 6.25d | 2018-10-27 | 2018-10-31 | C1C1111F5C760 | -0.5d | 0d | Helper [286 h]; Carpenter [715 h] | 70.37 | 11 | Civil | MB |
| C1C1111F5C790 |  | Base raft Zone-5 Formwork fixing column / inner wall | 3.75d | 2018-10-29 | 2018-10-31 | C1C1111F5C780 FF | -0.5d | 0d | Helper [128.7 h]; Carpenter [429 h] | 39.21 | 11 | Civil | MB |
| C1C1111F5C800 |  | Base raft Zone-5 West Formwork fixing wall (2nd Lift) | 3.75d | 2018-11-01 | 2018-11-04 | C1C1111F5C770, C1C1111F5C790 | -0.5d | 0d | Helper [171.6 h]; Carpenter [429 h] | 42.22 | 11 | Civil | MB |
| C1C1111F5C810 |  | Base raft Zone-5 Concrete Casting column / inner wall | 2.5d | 2018-11-01 | 2018-11-03 | C1C1111F5C790 | 0.75d | 0d | Concrete Casting [19.38 CUM]; Helper [143 h]; Mason [429 h] | 40.21 | 11 | Civil | MB |
| C1C1111F5C820 |  | Base raft Zone-5 East Concrete Casting & Striking wall (2nd Lift) | 2.5d | 2018-11-04 | 2018-11-05 | C1C1111F5C780, C1C1111F5C810 | 0.75d | 1.25d | Concrete Casting [83.96 CUM]; Helper [143 h]; Mason [429 h] | 40.21 | 11 | Civil | MB |
| C1C1111F5C830 |  | Base raft Zone-5 West Concrete Casting & Striking wall (2nd Lift) | 2.5d | 2018-11-05 | 2018-11-06 | C1C1111F5C820 FF, C1C1111F5C800, LOE-SUM1-070 FF | -0.5d | 0d | Concrete Casting [83.96 CUM]; Helper [143 h]; Mason [429 h] | 40.21 | 11 | Civil | MB |

| ID | WBS | Activity | Type | Duration | Start | Finish | Predecessors | Total float | Free float | Calendar | Resources | Cost | MILESTONE | Discipline | LOCATION | AREA |
| --- | --- | --- | --- | --- | --- | --- | --- | --- | --- | --- | --- | --- | --- | --- | --- | --- |
|  | 3 | **Central - 1st Stage Concrete on TRACK ACCESS LINE** |  |  | 2018-11-07 | 2018-11-18 |  |  |  |  |  |  |  |  |  |  |
| C1C1111F5C835 |  | MS1F5 - 1st stage Concrete complete P07- Zone-5 to 7 |  | 12.5d | 2018-11-07 | 2018-11-18 | C1C1111F5C830, LOE-SUM1-070 FF | 0d |  |  | Mason [750 h]; Concrete Casting [244.02 CUM]; Helper [286 h]; Carpenter [650 h]; Steel Fixer [650 h] | 164.24 | 10 | Civil | MB |  |
|  | 4 | **Platform Level (P06 ) . AREA-3** |  |  | 2018-11-03 | 2018-11-28 |  |  |  |  |  |  |  |  |  |  |
| LOE-SUM1-080 |  | Central . P06 - Concrete Works | level of effort | 28.75d | 2018-11-03 | 2018-11-28 | C1C1111F5C840 SS | -0.5d | 0d | Saudi |  |  |  | Civil |  |  |
|  | 1 | **Platform Level ( P06 . AREA-3)** |  |  | 2018-11-03 | 2018-11-28 |  |  |  |  |  |  |  |  |  |  |
| C1C1111F5C840 |  | P06- AREA-3 SE Formwork and Slab fixing |  | 7.5d | 2018-11-03 | 2018-11-08 | C1C1111F5C690, C1C1111F5C830 FF+2.5d, C1C1111F5C560 | -0.5d | 0d |  | Helper [343.2 h]; Carpenter [686.4 h] | 72.38 | 06 | Civil | MB | 3 |
| C1C1111F5C850 |  | P06-AREA-3 SW Formwork and Slab fixing |  | 7.5d | 2018-11-05 | 2018-11-11 | C1C1111F5C700, C1C1111F5C840 SS+2.5d | -0.5d | 0d |  | Helper [343.2 h]; Carpenter [686.4 h] | 72.38 | 06 | Civil | MB | 3 |
| C1C1111F5C860 |  | P06- AREA-3 Rebar fixing |  | 6.25d | 2018-11-10 | 2018-11-14 | C1C1111F5C840 | -0.5d | 0d |  | Helper [286 h]; Steel Fixer [715 h] | 70.37 | 06 | Civil | MB | 3 |
| C1C1111F5C870 |  | P06-AREA-3 Rebar fixing |  | 6.25d | 2018-11-12 | 2018-11-17 | C1C1111F5C850 | -0.5d | 0d |  | Helper [286 h]; Steel Fixer [715 h] | 70.37 | 06 | Civil | MB | 3 |
| C1C1111F5C880 |  | P06- AREA-3 SE Concrete Casting Slab |  | 2.5d | 2018-11-15 | 2018-11-17 | C1C1111F5C860, C1C1111F5C870 SS+2.5d | -0.5d | 0d |  | Concrete Casting [65.66 CUM]; Helper [143 h]; Mason [572 h] | 50.26 | 06 | Civil | MB | 3 |
| C1C1111F5C890 |  | P06-AREA-3 SW Concrete Casting Slab |  | 2.5d | 2018-11-18 | 2018-11-19 | C1C1111F5C870, C1C1111F5C880 | -0.5d | 0d |  | Concrete Casting [65.66 CUM]; Helper [143 h]; Mason [572 h] | 50.26 | 06 | Civil | MB | 3 |
| C1C1111F5C900 |  | P06- AREA-3 Rebar fixing column / inner wall |  | 3.75d | 2018-11-20 | 2018-11-22 | C1C1111F5C890 | -0.5d | 0d |  | Helper [286 h]; Steel Fixer [429 h] | 50.27 | 06 | Civil | MB | 3 |
| C1C1111F5C910 |  | P06- AREA-3 Formwork fixing column / inner wall |  | 3.75d | 2018-11-24 | 2018-11-26 | C1C1111F5C900 | -0.5d | 0d |  | Helper [257.4 h]; Carpenter [686.4 h] | 66.35 | 06 | Civil | MB | 3 |
| C1C1111F5C920 |  | P06-AREA-3 Concrete Casting column / inner wall |  | 2.5d | 2018-11-27 | 2018-11-28 | C1C1111F5C910, LOE-SUM1-080 FF | -0.5d | 0d |  | Concrete Casting [124.86 CUM]; Helper [143 h]; Mason [429 h] | 40.21 | 06 | Civil | MB | 3 |
|  | 5 | **Mezzanine Level Central ( AREA-3 )** |  |  | 2018-11-19 | 2019-01-01 |  |  |  |  |  |  |  |  |  |  |
| LOE-SUM1-090 |  | Central . B05 - Concrete Works | level of effort | 47.5d | 2018-11-19 | 2019-01-01 | C1C1111F5C930 SS, C1C1111F5C1070 SS | 3.25d | 0d | Saudi |  |  |  | Civil |  |  |
|  | 1 | **Mezzanine Level ( B05 . AREA-3 )** |  |  | 2018-11-19 | 2019-01-01 |  |  |  |  |  |  |  |  |  |  |
| C1C1111F5C930 |  | B05 - AREA-3 SE Formwork and Slab fixing |  | 6.25d | 2018-11-29 | 2018-12-04 | C1C1111F5C920 | -0.5d | 0d |  | Helper [343.2 h]; Carpenter [686.4 h] | 72.38 | 06 | Civil | MB | 3 |
| C1C1111F5C940 |  | B05 - AREA-3 SW Formwork and Slab fixing |  | 6.25d | 2018-11-29 | 2018-12-04 | C1C1111F5C930 SS | -0.5d | 0d |  | Helper [343.2 h]; Carpenter [686.4 h] | 72.38 | 06 | Civil | MB | 3 |
| C1C1111F5C950 |  | B05 - AREA-3 SE Rebar fixing |  | 6.25d | 2018-12-02 | 2018-12-06 | C1C1111F5C930 SS+2.5d, C1C1111F5C940 SS+2.5d | -0.5d | 0d |  | Helper [343.2 h]; Steel Fixer [858 h] | 84.45 | 06 | Civil | MB | 3 |
| C1C1111F5C960 |  | B05 - AREA-3 SW Rebar fixing |  | 6.25d | 2018-12-02 | 2018-12-06 | C1C1111F5C940 SS+2.5d | -0.5d | 0d |  | Helper [343.2 h]; Steel Fixer [858 h] | 84.45 | 06 | Civil | MB | 3 |
| C1C1111F5C970 |  | B05 - AREA-3 SE Concrete Casting Slab |  | 2.5d | 2018-12-08 | 2018-12-09 | C1C1111F5C835, C1C1111F5C960 SS+1.25d, C1C1111F5C950 | -0.5d | 0d |  | Concrete Casting [19.38 CUM]; Helper [114.4 h]; Mason [572 h] | 48.25 | 06 | Civil | MB | 3 |
| C1C1111F5C980 |  | B05 - AREA-3 SW Concrete Casting Slab |  | 2.5d | 2018-12-08 | 2018-12-09 | C1C1111F5C960, C1C1111F5C960 FF | -0.5d | 0d |  | Concrete Casting [18.84 CUM]; Helper [114.4 h]; Mason [572 h] | 48.25 | 06 | Civil | MB | 3 |
|  | 1 | **Mezzanine Level ( B05 AREA-3 .Walls )** |  |  | 2018-12-10 | 2019-01-01 |  |  |  |  |  |  |  |  |  |  |
| C1C1111F5C0990 |  | B05- AREA-3 Rebar fixing column / inner wall |  | 5d | 2018-12-10 | 2018-12-13 | C1C1111F5C980 SS+2.5d | 9.5d | 0d |  | Helper [228.8 h]; Steel Fixer [572 h] | 56.29 | 06 | Civil | MB | 3 |
| C1C1111F5C1000 |  | B05- AREA-3 Waterproofing wall (not by ZSCC) |  | 7.5d | 2018-12-10 | 2018-12-16 | C1C1111F5C970, C1C1111F5C980 | -0.5d | 0d |  |  |  | 06 | Civil | MB | 3 |
| C1C1111F5C1010 |  | B05- AREA-3 Formwork fixing column / inner wall |  | 5d | 2018-12-15 | 2018-12-18 | C1C1111F5C0990 | 9.5d | 0d |  | Helper [228.8 h]; Carpenter [343.2 h] | 40.21 | 06 | Civil | MB | 3 |
| C1C1111F5C1030 |  | B05- AREA-3 Rebar fixing wall |  | 8.75d | 2018-12-16 | 2018-12-23 | C1C1111F5C1000 FF+7.5d | -0.5d | 0d |  | Helper [400.4 h]; Steel Fixer [840 h] | 87.2 | 06 | Civil | MB | 3 |
| C1C1111F5C1040 |  | B05- AREA-3 Concrete Casting column / inner wall |  | 2.5d | 2018-12-19 | 2018-12-20 | C1C1111F5C1010 | 9.5d | 10d |  | Concrete Casting [254.03 CUM]; Helper [143 h]; Mason [429 h] | 40.21 | 06 | Civil | MB | 3 |
| C1C1111F5C1050 |  | B05- AREA-3 Formwork fixing wall |  | 8.75d | 2018-12-23 | 2018-12-30 | C1C1111F5C1030 FF+7.5d | -0.5d | 0d |  | Helper [400.4 h]; Carpenter [840 h] | 87.2 | 06 | Civil | MB | 3 |
| C1C1111F5C1060 |  | B05- AREA-3 Concrete Casting & Striking wall |  | 2.5d | 2018-12-31 | 2019-01-01 | C1C1111F5C1040, C1C1111F5C1050, LOE-SUM1-090 FF | -0.5d | 0d |  | Concrete Casting [233.58 CUM]; Helper [143 h]; Mason [429 h] | 40.21 | 06 | Civil | MB | 3 |

| ID | WBS | Activity | Type | Duration | Start | Finish | Predecessors | Total float | Free float | Calendar | Resources | Cost | MILESTONE | Discipline | AREA | LOCATION |
| --- | --- | --- | --- | --- | --- | --- | --- | --- | --- | --- | --- | --- | --- | --- | --- | --- |
|  | 4 | **Mezzanine Level ( B05 . OTE AREA-3 )** |  |  | 2018-11-19 | 2018-12-24 |  |  |  |  |  |  |  |  |  |  |
|  | 3 | **Mezzanine Level ( B05 . OTE AREA-3) Lower Part** |  |  | 2018-11-19 | 2018-12-04 |  |  |  |  |  |  |  |  |  |  |
| C1C1111F5C1070 |  | B05- AREA-3 Formwork |  | 7.5d | 2018-11-19 | 2018-11-25 | C1C1111F5C835 | 12d | 0d |  | Helper [480 h]; Carpenter [720 h] | 84.36 | 06 | Civil | 3 | MB |
| C1C1111F5C1080 |  | B05-AREA-3 Rebar fixing |  | 7.5d | 2018-11-26 | 2018-12-02 | C1C1111F5C1070 | 12d | 0d |  | Helper [600 h]; Steel Fixer [720 h] | 92.8 | 06 | Civil | 3 | MB |
| C1C1111F5C1090 |  | B05-AREA-3 Concrete Casting Slab |  | 2.5d | 2018-12-03 | 2018-12-04 | C1C1111F5C1080 | 12d | 0d |  | Concrete Casting [86.11 CUM]; Helper [114.4 h]; Mason [171.6 h] | 20.1 | 06 | Civil | 3 | MB |
|  | 1 | **Mezzanine Level ( B05 . OTE AREA-3 ) Upper Part** |  |  | 2018-12-05 | 2018-12-24 |  |  |  |  |  |  |  |  |  |  |
| C1C1111F5C1100 |  | B05- AREA-3 Formwork |  | 7.5d | 2018-12-05 | 2018-12-11 | C1C1111F5C1090 | 12d | 0d |  | Helper [686.4 h]; Carpenter [1029.6 h] | 120.63 | 06 | Civil | 3 | MB |
| C1C1111F5C1110 |  | B05-AREA-3 Rebar fixing |  | 7.5d | 2018-12-12 | 2018-12-18 | C1C1111F5C1100 | 12d | 0d |  | Helper [480 h]; Steel Fixer [900 h] | 97.01 | 06 | Civil | 3 | MB |
| C1C1111F5C1120 |  | B05-AREA-3 Concrete Casting Slab |  | 2.5d | 2018-12-23 | 2018-12-24 | C1C1111F5C1110 FS+3.75d, LOE-SUM1-090 FF | 12d | 12.5d |  | Concrete Casting [48.98 CUM]; Helper [114.4 h]; Mason [171.6 h] | 20.1 | 06 | Civil | 3 | MB |
|  | 6 | **Technical Level (B-04 ) Central ( AREA-3 )** |  |  | 2019-01-02 | 2019-03-31 |  |  |  |  |  |  |  |  |  |  |
| LOE-SUM1-100 |  | Central . B04 - Concrete Works | level of effort | 48.75d | 2019-01-02 | 2019-02-16 | C1C1111F5C1130 SS | 67d | 0d | Saudi |  |  |  | Civil |  |  |
|  | 1 | **Technical Level (B-04 . AREA-3 )** |  |  | 2019-01-02 | 2019-03-31 |  |  |  |  |  |  |  |  |  |  |
| C1C1111F5C1130 |  | B04- AREA-3 SE Formwork and Slab fixing |  | 7.5d | 2019-01-02 | 2019-01-08 | C1C1111F5C1120 FF+3.75d, C1C1111F5C1060 | -0.5d | 0d |  | Carpenter [686.4 h]; Helper [343.2 h] | 72.38 | 06 | Civil | 3 | MB |
| C1C1111F5C1140 |  | B04 - AREA-3 Rebar fixing |  | 7.5d | 2019-01-08 | 2019-01-14 | B520 FS+22.5d, C1C1111F5C1130 FF+6.25d | -0.5d | 0d |  | Steel Fixer [858 h]; Helper [343.2 h] | 84.45 | 06 | Civil | 3 | MB |
| C1C1111F5C1150 |  | B04- AREA-3 Technical Concrete Casting Slab |  | 2.5d | 2019-01-15 | 2019-01-16 | C1C1111F5C1140 | -0.5d | 0d |  | Concrete Casting [411.19 CUM]; Mason [572 h]; Helper [114.4 h] | 48.25 | 06 | Civil | 3 | MB |
|  | 1 | **Technical Level (B-04 AREA-3 .Walls)** |  |  | 2019-01-17 | 2019-02-09 |  |  |  |  |  |  |  |  |  |  |
| C1C1111F5C1160 |  | B04- AREA-3 Rebar fixing column / inner wall |  | 5d | 2019-01-17 | 2019-01-21 | C1C1111F5C1150 | 9.5d | 0d |  | Steel Fixer [572 h]; Helper [228.8 h] | 56.29 | 07 | Civil | 3 | MB |
| C1C1111F5C1170 |  | B04- AREA-3 Waterproofing wall (not by ZSCC) |  | 7.5d | 2019-01-17 | 2019-01-23 | C1C1111F5C1150 | -0.5d | 0d |  |  |  | 07 | Civil | 3 | MB |
| C1C1111F5C1180 |  | B04- AREA-3 Formwork fixing column / inner wall |  | 5d | 2019-01-22 | 2019-01-26 | C1C1111F5C1160 | 9.5d | 0d |  | Carpenter [457.6 h]; Helper [286 h] | 52.28 | 07 | Civil | 3 | MB |
| C1C1111F5C1190 |  | B04- AREA-3 Rebar fixing wall |  | 7.5d | 2019-01-24 | 2019-01-30 | C1C1111F5C1170 | -0.5d | 0d |  | Steel Fixer [720 h]; Helper [457.6 h] | 82.79 | 07 | Civil | 3 | MB |
| C1C1111F5C1200 |  | B04- AREA-3 Concrete Casting column / inner wall |  | 2.5d | 2019-01-27 | 2019-01-28 | C1C1111F5C1180 | 9.5d | 10d |  | Concrete Casting [373.52 CUM]; Mason [429 h]; Helper [171.6 h] | 42.22 | 07 | Civil | 3 | MB |
| C1C1111F5C1210 |  | B04- AREA-3 Formwork fixing wall |  | 7.5d | 2019-01-31 | 2019-02-06 | C1C1111F5C1190 | -0.5d | 0d |  | Carpenter [858 h]; Helper [343.2 h] | 84.45 | 07 | Civil | 3 | MB |
| C1C1111F5C1220 |  | B04- AREA-3 Concrete Casting & Striking wall |  | 2.5d | 2019-02-07 | 2019-02-09 | C1C1111F5C1200, C1C1111F5C1210, LOE-SUM1-100 FF | -0.5d | 0d |  | Concrete Casting [244.35 CUM]; Mason [429 h]; Helper [171.6 h] | 42.22 | 07 | Civil | 3 | MB |
|  | 2 | **Staircases P06 to B04 Level, bet GL 8 to 14, West & East** |  |  | 2019-01-24 | 2019-03-31 |  |  |  |  |  |  |  |  |  |  |
|  | 1 | **Stair Cases - 3 Flights from P06 to B04 Level, bet GL 12 to 14** |  |  | 2019-01-24 | 2019-02-18 |  |  |  |  |  |  |  |  |  |  |
| C1C1111F5CS010 |  | B04- AREA-3 Formwork and Slab fixing |  | 12.5d | 2019-01-24 | 2019-02-04 | C1C1111F5C1150 FS+7.5d | 50.75d | 0d |  | Carpenter [480 h]; Helper [286 h] | 53.85 | 07 | Civil | 3 | MB |
| C1C1111F5CS020 |  | B04- AREA-3 Rebar fixing wall |  | 12.5d | 2019-02-05 | 2019-02-16 | C1C1111F5C1150 FS+7.5d, C1C1111F5CS010 | 67d | 0d |  | Steel Fixer [572 h]; Helper [228.8 h] | 56.29 | 07 | Civil | 3 | MB |
| C1C1111F5CS030 |  | B04- AREA-3 Concrete Casting Slab |  | 2.5d | 2019-02-17 | 2019-02-18 | C1C1111F5CS020, LOE-SUM1-100 | 67d | 43.75d |  | Concrete Casting; Helper [143 h]; Mason [400 h] | 38.17 | 07 | Civil | 3 | MB |

| ID | WBS | Activity | Type | Duration | Start | Finish | Predecessors | Total float | Free float | Calendar | Resources | Cost | MILESTONE | Discipline | AREA | LOCATION |
| --- | --- | --- | --- | --- | --- | --- | --- | --- | --- | --- | --- | --- | --- | --- | --- | --- |
|  | 2 | **Stair Cases - 3 Flights from P06 to B04 Level, bet GL 8 to 10** |  |  | 2019-03-06 | 2019-03-31 |  |  |  |  |  |  |  |  |  |  |
| C1C1111F5CS040 |  | B04- AREA-3 Formwork and Slab fixing |  | 12.5d | 2019-03-06 | 2019-03-17 | C1C1111F5N1520 FS+7.5d, C1C1111F5CS010 | 19.5d | 0d |  | Carpenter [480 h]; Helper [286 h] | 53.85 | 07 | Civil | 3 | MB |
| C1C1111F5CS050 |  | B04- AREA-3 Rebar fixing wall |  | 12.5d | 2019-03-18 | 2019-03-28 | C1C1111F5CS040 | 23.25d | 0d |  | Steel Fixer [572 h]; Helper [228.8 h] | 56.29 | 07 | Civil | 3 | MB |
| C1C1111F5CS060 |  | B04- AREA-3 Concrete Casting Slab |  | 2.5d | 2019-03-30 | 2019-03-31 | C1C1111F5CS050, C1C1111F5CS030 FF | 23.25d | 3.75d |  | Concrete Casting; Helper [143 h]; Mason [400 h] | 38.17 | 07 | Civil | 3 | MB |
|  | 7 | **Concourse Level B03 Central ( AREA-3 )** |  |  | 2019-02-10 | 2019-04-03 |  |  |  |  |  |  |  |  |  |  |
| LOE-SUM1-110 |  | Central . B03 - Concrete Works | level of effort | 57.5d | 2019-02-10 | 2019-04-03 | C1C1111F5C1760 SS | 19.5d | 0d | Saudi |  |  |  | Civil |  |  |
|  | 1 | **Concourse Level ( B03 . AREA-3 )** |  |  | 2019-02-10 | 2019-03-17 |  |  |  |  |  |  |  |  |  |  |
| C1C1111F5C1760 |  | B03- AREA-3 Formwork and Slab fixing |  | 7.5d | 2019-02-10 | 2019-02-16 | C1C1111F5C1220 | -0.5d | 0d |  | Helper [343.2 h]; Carpenter [686.4 h] | 72.38 | 07 | Civil | 3 | MB |
| C1C1111F5C1770 |  | B03- AREA-3 Rebar fixing |  | 6.25d | 2019-02-17 | 2019-02-21 | B570 FS+32.5d, C1C1111F5C1760 | -0.5d | 0d |  | Helper [343.2 h]; Steel Fixer [715 h] | 74.39 | 07 | Civil | 3 | MB |
| C1C1111F5C1780 |  | B03- AREA-3 Concrete Casting Slab |  | 2.5d | 2019-02-23 | 2019-02-24 | C1C1111F5C1770 | -0.5d | 0d |  | Concrete Casting [239.18 CUM]; Helper [143 h]; Mason [572 h] | 50.26 | 07 | Civil | 3 | MB |
| C1C1111F5C1785 |  | B03- AREA-3 Waterproofing wall (not by ZSCC) |  | 7.5d | 2019-02-25 | 2019-03-03 | C1C1111F5C1780 | -0.5d | 0d |  |  |  | 07 | Civil | 3 | MB |
| C1C1111F5C1790 |  | B03- AREA-3 Rebar fixing wall / column / staircase |  | 7.5d | 2019-03-04 | 2019-03-10 | C1C1111F5C1785 | -0.5d | 0d |  | Helper [457.6 h]; Steel Fixer [686.4 h] | 80.42 | 07 | Civil | 3 | MB |
| C1C1111F5C1800 |  | B03- AREA-3 Formwork fixing wall / column / staircase |  | 7.5d | 2019-03-09 | 2019-03-14 | C1C1111F5C1790 SS+5d | -0.5d | 0d |  | Helper [457.6 h]; Carpenter [686.4 h] | 80.42 | 07 | Civil | 3 | MB |
| C1C1111F5C1810 |  | B03- AREA-3 Concrete Casting wall / column / staircase |  | 2.5d | 2019-03-16 | 2019-03-17 | C1C1111F5C1800, LOE-SUM1-110 FF | -0.5d | 0d |  | Concrete Casting [149.44 CUM]; Helper [143 h]; Mason [429 h] | 40.21 | 07 | Civil | 3 | MB |
|  | 2 | **Stair Cases - 2 Flights from B04 to B03 Level, bet GL 8 to 10, West & East** |  |  | 2019-03-10 | 2019-04-03 |  |  |  |  |  |  |  |  |  |  |
| C1C1111F5CS070 |  | B03- AREA-3 Formwork and Slab fixing |  | 12.5d | 2019-03-10 | 2019-03-20 | C1C1111F5C1780 FS+7.5d, C1C1111F5CS040 SS+3.75d | 19.5d | 0d |  | Carpenter [480 h]; Helper [286 h] | 53.85 | 07 | Civil | 3 | MB |
| C1C1111F5CS080 |  | B03- AREA-3 Rebar fixing wall |  | 12.5d | 2019-03-21 | 2019-04-01 | C1C1111F5CS070 | 19.5d | 0d |  | Steel Fixer [572 h]; Helper [228.8 h] | 56.29 | 07 | Civil | 3 | MB |
| C1C1111F5CS090 |  | B03- AREA-3 Concrete Casting Slab |  | 2.5d | 2019-04-02 | 2019-04-03 | C1C1111F5CS080, C1C1111F5CS060 FF, LOE-SUM1-110 FF | 19.5d | 20d |  | Concrete Casting; Helper [143 h]; Mason [400 h] | 38.17 | 07 | Civil | 3 | MB |
|  | 8 | **TV Louver Level B02 Central ( AREA-3 )** |  |  | 2019-03-18 | 2019-04-22 |  |  |  |  |  |  |  |  |  |  |
| LOE-SUM1-120 |  | Central . B02 - Concrete Works | level of effort | 38.75d | 2019-03-18 | 2019-04-22 | C1C1111F5C1820 SS | -0.5d | 0d | Saudi |  |  |  | Civil |  |  |
|  | 1 | **TV Louver Level ( B02 . AREA-3 )** |  |  | 2019-03-18 | 2019-04-22 |  |  |  |  |  |  |  |  |  |  |
| C1C1111F5C1820 |  | B02- AREA-3 Formwork and Slab fixing |  | 7.5d | 2019-03-18 | 2019-03-24 | C1C1111F5C1810 | -0.5d | 0d |  | Helper [343.2 h]; Carpenter [686.4 h] | 72.38 | 07 | Civil | 3 | MB |
| C1C1111F5C1830 |  | B02- AREA-3 Rebar fixing |  | 6.25d | 2019-03-25 | 2019-03-30 | C1C1111F5C1820, B620 FS+32.5d | -0.5d | 0d |  | Helper [343.2 h]; Steel Fixer [715 h] | 74.39 | 07 | Civil | 3 | MB |
| C1C1111F5C1840 |  | B02- AREA-3 Concrete Casting Slab |  | 2.5d | 2019-03-31 | 2019-04-01 | C1C1111F5C1830 | -0.5d | 0d |  | Concrete Casting [83.96 CUM]; Helper [143 h]; Mason [572 h] | 50.26 | 07 | Civil | 3 | MB |
| C1C1111F5C1850 |  | B02- AREA-3 Waterproofing wall (not by ZSCC) |  | 7.5d | 2019-04-02 | 2019-04-08 | C1C1111F5C1840 | -0.5d | 0d |  |  |  | 07 | Civil | 3 | MB |
| C1C1111F5C1860 |  | B02- AREA-3 Rebar fixing wall / column / staircase |  | 7.5d | 2019-04-09 | 2019-04-15 | C1C1111F5C1850, C1C1111F5C1840 | -0.5d | 0d |  | Helper [457.6 h]; Steel Fixer [840 h] | 91.22 | 07 | Civil | 3 | MB |
| C1C1111F5C1870 |  | B02- AREA-3 Formwork fixing wall / column / staircase |  | 7.5d | 2019-04-14 | 2019-04-20 | C1C1111F5C1860 SS+5d | -0.5d | 0d |  | Helper [457.6 h]; Carpenter [840 h] | 91.22 | 07 | Civil | 3 | MB |
| C1C1111F5C1880 |  | B02- AREA-3 Concrete Casting wall / column / staircase |  | 2.5d | 2019-04-21 | 2019-04-22 | C1C1111F5C1870, C1C1111F5CS090 FF, LOE-SUM1-120 FF | -0.5d | 0d |  | Concrete Casting [231.75 CUM]; Helper [143 h]; Mason [429 h] | 40.21 | 07 | Civil | 3 | MB |

| ID | WBS | Activity | Type | Duration | Start | Finish | Predecessors | Total float | Free float | Constraint | Calendar | Resources | Cost | Discipline | MILESTONE | AREA | LOCATION |
| --- | --- | --- | --- | --- | --- | --- | --- | --- | --- | --- | --- | --- | --- | --- | --- | --- | --- |
|  | 9 | **Top Slab Level B01 Central ( AREA-3 )** |  |  | 2019-04-23 | 2019-05-08 |  |  |  |  |  |  |  |  |  |  |  |
| LOE-SUM1-130 |  | Central . B01 - Concrete Works | level of effort | 17.5d | 2019-04-23 | 2019-05-08 | C1C1111F5C1890 SS | -0.5d | 0d |  | Saudi |  |  | Civil |  |  |  |
|  | 1 | **Top Slab Level ( B01 . AREA-3 )** |  |  | 2019-04-23 | 2019-05-08 |  |  |  |  |  |  |  |  |  |  |  |
| C1C1111F5C1890 |  | B01- AREA-3 Formwork and Slab fixing |  | 7.5d | 2019-04-23 | 2019-04-29 | B670 FS+32.5d, C1C1111F5C1880 | -0.5d | 0d |  |  | Helper [343.2 h]; Carpenter [686.4 h] | 72.38 | Civil | 07 | 3 | MB |
| C1C1111F5C1900 |  | B01- AREA-3 Rebar fixing |  | 7.5d | 2019-04-30 | 2019-05-06 | C1C1111F5C1890, C1C1111F5C1890 SS+5d | -0.5d | 0d |  |  | Helper [343.2 h]; Steel Fixer [715 h] | 74.39 | Civil | 07 | 3 | MB |
| C1C1111F5C1910 |  | B01- AREA-3 Concrete Casting Slab |  | 2.5d | 2019-05-07 | 2019-05-08 | C1C1111F5C1890 SS, C1C1111F5C1900, LOE-SUM1-130 FF | -0.5d | 0d |  |  | Concrete Casting [841.33 CUM]; Helper [143 h]; Mason [572 h] | 50.26 | Civil | 07 | 3 | MB |
|  | 10 | **Paraphet Wall above Top Slab Central ( B01 . AREA-3)** |  |  | 2019-05-09 | 2019-06-15 |  |  |  |  |  |  |  |  |  |  |  |
| LOE-SUM1-140 |  | Central . B01 - Concrete Works | level of effort | 40d | 2019-05-09 | 2019-06-15 | C1C1111F5C1930 SS | 38.25d | 0d |  | Saudi |  |  | Civil |  |  |  |
|  | 1 | **Paraphet Wall above Top Slab ( B01 . AREA-3)** |  |  | 2019-05-09 | 2019-06-15 |  |  |  |  |  |  |  |  |  |  |  |
| C1C1111F5C1930 |  | B01- AREA-3 Rebar fixing column / wall / staircase |  | 7.5d | 2019-05-09 | 2019-05-15 | C1C1111F5C1910, C1C1111F5C2030 FF | -0.5d | 0d |  |  | Steel Fixer [858 h]; Helper [400.4 h] | 88.47 | Civil |  | 3 | MB |
| C1C1111F5C1940 |  | B01- AREA-3 Formwork fixing column / wall/ staircase |  | 7.5d | 2019-05-16 | 2019-05-22 | C1C1111F5C1930, C1C1111F5C2040 FF | -0.5d | 0d |  |  | Helper [343.2 h]; Carpenter [858 h] | 84.45 | Civil |  | 3 | MB |
| C1C1111F5C1950 |  | B01- AREA-3 Concrete Casting column / wall / staircase |  | 2.5d | 2019-05-23 | 2019-05-25 | C1C1111F5C2010 FF, C1C1111F5C1940, CM080 FF | -0.5d | 0d |  |  | Concrete Casting [92.84 CUM]; Helper [143 h]; Mason [429 h] | 40.21 | Civil |  | 3 | MB |
| C1C1111F5C1960 |  | B01- AREA-3 Waterproofing wall (not by ZSCC) |  | 7.5d | 2019-05-26 | 2019-06-01 | C1C1111F5C1910, C1C1111F5C1950 | 38.25d | 0d |  |  |  |  | Civil |  | 3 | MB |
| C1C1111F5C1970 |  | B01- AREA-3 Protection Screed |  | 3.75d | 2019-06-02 | 2019-06-08 | C1C1111F5C1960 | 38.25d | 0d |  |  | Helper [128.7 h]; Mason [257.4 h] | 27.15 | Civil |  | 3 | MB |
| C1C1111F5C1980 |  | B01- AREA-3 Backfilling & compaction (Optional) |  | 7.5d | 2019-06-09 | 2019-06-15 | C1C1111F5C1970 FF, C1C1111F5C1970, LOE-SUM1-140 FF | 38.25d | 6.25d |  |  | Helper [514.8 h] | 36.19 | Civil |  | 3 | MB |
|  | 11 | **LOE Commodities Civil - Central ( B01 to B07)** |  |  | 2018-09-03 | 2019-05-25 |  |  |  |  |  |  |  |  |  |  |  |
| C1C1111F5C2010 |  | LOE - Mass concrete infill between pemanent wall and SOE | level of effort | 283.75d | 2018-09-03 | 2019-05-25 | C1C1111F5C340 SS | -0.5d | 0d |  |  | Concrete infill [718 CUM] |  | Civil |  |  | MB |
| C1C1111F5C2030 |  | LOE - Central B07 to B01 - Rebar | level of effort | 265d | 2018-09-11 | 2019-05-15 | C1C1111F5C360 SS | -0.5d | 0d |  |  | Steel Reinforcement [1253.43 tons] |  | Civil |  |  | MB |
| C1C1111F5C2040 |  | LOE - Central B07 to B01 - Formworks | level of effort | 263.75d | 2018-09-19 | 2019-05-22 | C1C1111F5C370 SS | -0.5d | 0d |  |  | Formworks [12968.7 Square Meter] |  | Civil |  |  | MB |
|  | 3 | **NORTH MAIN BOX Concrete Works (Zone 4 to Zone 1)** |  |  | 2018-10-06 | 2019-07-21 |  |  |  |  |  |  |  |  |  |  |  |
|  | 2 | **Base Raft - North (Zone 4 to Zone 1)** |  |  | 2018-10-06 | 2018-12-24 |  |  |  |  |  |  |  |  |  |  |  |
| LOE-SUM1-150 |  | North . B01 - Concrete Works | level of effort | 78.75d | 2018-10-13 | 2018-12-24 | C1C1111F5N310 | -2.5d | 0d |  | Saudi |  |  | Civil |  |  |  |
|  | 1 | **Base Raft - Zone 4 (25.05 x 14.20 , 1070 m3)** |  |  | 2018-10-06 | 2018-10-30 |  |  |  |  |  |  |  |  |  |  |  |
| C1C1111F5N310 |  | Base raft Zone-4 Waterproofing Wall (not by ZSCC), Base raft & Blindiing |  | 7.5d | 2018-10-06 | 2018-10-11 | C1C1111F5C430 | -1.25d | 0d | finish on or after 2018-10-11 |  |  |  | Civil | 09 |  | MB |
| C1C1111F5N320 |  | Base raft Zone-4 Rebar fixing |  | 11.25d | 2018-10-13 | 2018-10-22 | C1C1111F5N310 | 0d |  |  |  | Helper [386.1 h]; Steel Fixer [1029.6 h] | 99.52 | Civil | 09 |  | MB |
| C1C1111F5N330 |  | Base raft Zone-4 Formwork fixing |  | 6.25d | 2018-10-23 | 2018-10-28 | C1C1111F5N320 | 0d |  |  |  | Helper [214.5 h]; Carpenter [572 h] | 55.29 | Civil | 09 |  | MB |
| C1C1111F5N340 |  | Base raft Zone-4 Concrete Casting base raft |  | 2.5d | 2018-10-29 | 2018-10-30 | C1C1111F5N330, C1C1111F5C420 | 0d |  |  |  | Mason [429 h]; Concrete Casting [964.9 CUM]; Helper [143 h] | 40.21 | Civil | 09 |  | MB |

| ID | WBS | Activity | Duration | Start | Finish | Predecessors | Total float | Free float | Constraint | Resources | Cost | MILESTONE | Discipline | LOCATION |
| --- | --- | --- | --- | --- | --- | --- | --- | --- | --- | --- | --- | --- | --- | --- |
|  | 2 | **Base Raft - Zone 3 (25.05 x 13.0 , 1010 m3)** |  | 2018-10-24 | 2018-11-18 |  |  |  |  |  |  |  |  |  |
| C1C1111F5N350 |  | Base raft Zone-3 Waterproofing Wall (not by ZSCC), Base raft & Blindiing | 7.5d | 2018-10-24 | 2018-10-30 | C1C1111F5N310 | -13.75d | 0d | finish on or after 2018-10-30 |  |  | 09 | Civil | MB |
| C1C1111F5N360 |  | Base raft Zone-3 Rebar fixing | 11.25d | 2018-10-31 | 2018-11-10 | C1C1111F5N350 | -7.5d | 0d |  | Helper [386.1 h]; Steel Fixer [1029.6 h] | 99.52 | 09 | Civil | MB |
| C1C1111F5N370 |  | Base raft Zone-3 Formwork fixing | 6.25d | 2018-11-11 | 2018-11-15 | C1C1111F5N360 | -7.5d | 0d |  | Helper [214.5 h]; Carpenter [572 h] | 55.29 | 09 | Civil | MB |
| C1C1111F5N380 |  | Base raft Zone-3 Concrete Casting base raft | 2.5d | 2018-11-17 | 2018-11-18 | C1C1111F5N340 FF, C1C1111F5N370, C1C1111F5N340 | -7.5d | 0d |  | Mason [429 h]; Concrete Casting [883.41 CUM]; Helper [143 h] | 40.21 | 09 | Civil | MB |
|  | 4 | **Base Raft - Zone 1 (North East Box from CL, 12.5x 29.78, 1245 m3)** |  | 2018-11-01 | 2018-11-24 |  |  |  |  |  |  |  |  |  |
| C1C1111F5N480 |  | Base raft Zone-1 Waterproofing Wall (not by ZSCC), Base raft & Blindiing | 7.5d | 2018-11-01 | 2018-11-07 | C1C1111F5N350 | -15d | 0d | start on or after 2018-10-31 |  |  | 09 | Civil | MB |
| C1C1111F5N490 |  | Base raft Zone-1 Rebar fixing | 10d | 2018-11-08 | 2018-11-17 | C1C1111F5N480 | -10d | 0d |  | Steel Fixer [915.2 h]; Helper [386.1 h] | 91.48 | 09 | Civil | MB |
| C1C1111F5N500 |  | Base raft Zone-1 Formwork fixing | 5d | 2018-11-18 | 2018-11-21 | C1C1111F5N490 | -10d | 0d |  | Helper [214.5 h]; Carpenter [457.6 h] | 47.25 | 09 | Civil | MB |
| C1C1111F5N510 |  | Base raft Zone-1 Concrete Casting base raft | 2.5d | 2018-11-22 | 2018-11-24 | C1C1111F5N500 | -10d | 0d | finish on or before 2018-11-18 | Mason [429 h]; Concrete Casting [1009.79 CUM]; Helper [143 h] | 40.21 | 09 | Civil | MB |
|  | 3 | **Base Raft - Zone 2 (North West Box with Sump )** |  | 2018-11-04 | 2018-12-02 |  |  |  |  |  |  |  |  |  |
|  | 1 | **Base Raft - Zone 2 (Sump)** |  | 2018-11-04 | 2018-11-19 |  |  |  |  |  |  |  |  |  |
| C1C1111F5N390 |  | Base raft Zone-2 Waterproofing ( by BACS), Base raft & Blindiing | 5d | 2018-11-04 | 2018-11-07 | C1C1111F5N440 SS, C1C1111F5N480 SS | -15d | 0d |  |  |  | 09 | Civil | MB |
| C1C1111F5N400 |  | Base raft Zone-2 Rebar fixing | 5d | 2018-11-08 | 2018-11-12 | C1C1111F5N390 | -15d | 0d |  | Helper [386.1 h]; Steel Fixer [915.2 h] | 91.48 | 09 | Civil | MB |
| C1C1111F5N410 |  | Base raft Zone-2 Formwork fixing | 5d | 2018-11-13 | 2018-11-17 | C1C1111F5N400 | -15d | 0d |  | Helper [214.5 h]; Carpenter [457.6 h] | 47.25 | 09 | Civil | MB |
| C1C1111F5N420 |  | Base raft Zone-2 Concrete Casting for Sump | 2.5d | 2018-11-18 | 2018-11-19 | C1C1111F5N410 | -15d | 0d |  | Concrete Casting [17.76 CUM]; Helper [143 h]; Mason [429 h] | 40.21 | 09 | Civil | MB |
|  | 2 | **Base Raft - Zone 2 (North West Box from CL , 12.5x 29.78 ,1420 m3)** |  | 2018-11-04 | 2018-12-02 |  |  |  |  |  |  |  |  |  |
| C1C1111F5N440 |  | Base raft Zone-2 Waterproofing Wall (not by ZSCC), Base raft & Blindiing | 7.5d | 2018-11-04 | 2018-11-10 | C1C1111F5N480 SS | -15d | 0d | start on or after 2018-11-03 |  |  | 09 | Civil | MB |
| C1C1111F5N450 |  | Base raft Zone-2 Rebar fixing | 10d | 2018-11-14 | 2018-11-22 | C1C1111F5N440, C1C1111F5N420 FF+3.75d | -15d | 0d |  | Helper [386.1 h]; Steel Fixer [915.2 h] | 91.48 | 09 | Civil | MB |
| C1C1111F5N460 |  | Base raft Zone-2 Formwork fixing | 7.5d | 2018-11-24 | 2018-11-29 | C1C1111F5N420 FF, C1C1111F5N450 | -15d | 0d |  | Helper [214.5 h]; Carpenter [686.4 h] | 63.33 | 09 | Civil | MB |
| C1C1111F5N470 |  | Base raft Zone-2 Concrete Casting base raft | 2.5d | 2018-12-01 | 2018-12-02 | C1C1111F5N420 FF, C1C1111F5N510, C1C1111F5N460, C1C1111F5N380 FS-12.5d | -15d | 0d | finish on or before 2018-11-18 | Mason [429 h]; Concrete Casting [1009.79 CUM]; Helper [143 h] | 40.21 | 09 | Civil | MB |
|  | 3 | **Outer & Inner Wall -Zone 4 to Zone 1- ( Base Raft to Mezzanine Floor)** |  | 2018-10-31 | 2018-12-24 |  |  |  |  |  |  |  |  |  |
|  | 1 | **Outer & Inner Wall Zone 4** |  | 2018-10-31 | 2018-11-28 |  |  |  |  |  |  |  |  |  |
| C1C1111F5N520 |  | Base raft Zone-4 Waterproofing Wall (not by ZSCC) | 5d | 2018-10-31 | 2018-11-04 | C1C1111F5N340 | 0d |  |  |  |  | 10 | Civil | MB |
| C1C1111F5N530 |  | Base raft Zone-4 West Rebar fixing wall | 5d | 2018-11-05 | 2018-11-08 | C1C1111F5C720, C1C1111F5N520, C1C1111F5N340 | 0d |  |  | Helper [171.6 h]; Steel Fixer [572 h] | 52.27 | 10 | Civil | MB |
| C1C1111F5N540 |  | Base raft Zone-4 East Rebar fixing wall | 5d | 2018-11-05 | 2018-11-08 | C1C1111F5N530 SS | 0d |  |  | Helper [171.6 h]; Steel Fixer [572 h] | 52.27 | 10 | Civil | MB |
| C1C1111F5N550 |  | Base raft Zone-4 Rebar fixing column / inner wall | 5d | 2018-11-10 | 2018-11-13 | C1C1111F5N540 | 0d |  |  | Helper [171.6 h]; Steel Fixer [572 h] | 52.27 | 10 | Civil | MB |
| C1C1111F5N560 |  | Base raft Zone-4 East Formwork fixing wall (1st Lift ) | 5d | 2018-11-10 | 2018-11-13 | C1C1111F5N550 SS | 0d |  |  | Helper [143 h]; Carpenter [572 h] | 50.26 | 10 | Civil | MB |
| C1C1111F5N570 |  | Base raft Zone-4 West Formwork fixing wall ( 1st Lift ) | 5d | 2018-11-10 | 2018-11-13 | C1C1111F5N560 SS | 2.5d |  |  | Helper [143 h]; Carpenter [572 h] | 50.26 | 10 | Civil | MB |
| C1C1111F5N580 |  | Base raft Zone-4 East Concrete Casting & Striking wall ( 1st Lift ) | 2.5d | 2018-11-14 | 2018-11-15 | C1C1111F5N560 | 0d |  |  | Mason [429 h]; Concrete Casting [43.06 CUM]; Helper [143 h] | 40.21 | 10 | Civil | MB |
| C1C1111F5N590 |  | Base raft Zone-4 West Concrete Casting & Striking wall (1st Lift ) | 2.5d | 2018-11-17 | 2018-11-18 | C1C1111F5N570, C1C1111F5N580 | 0d | 2.5d |  | Mason [429 h]; Concrete Casting [43.06 CUM]; Helper [143 h] | 40.21 | 10 | Civil | MB |
| C1C1111F5N600 |  | Base raft Zone-4 East Formwork fixing wall (2nd Lift) | 6.25d | 2018-11-17 | 2018-11-21 | C1C1111F5N580 | 20.75d | 0d |  | Helper [214.5 h]; Carpenter [715 h] | 65.34 | 11 | Civil | MB |
| C1C1111F5N610 |  | Base raft Zone-4 Formwork fixing column / inner wall | 3.75d | 2018-11-19 | 2018-11-21 | C1C1111F5N550, C1C1111F5N600 FF | 20.75d | 0d |  | Helper [128.7 h]; Carpenter [429 h] | 39.21 | 11 | Civil | MB |
| C1C1111F5N620 |  | Base raft Zone-4 West Formwork fixing wall (2nd Lift) | 6.25d | 2018-11-21 | 2018-11-26 | C1C1111F5N610 FF+5d, C1C1111F5N590 | 20.75d | 0d |  | Helper [128.7 h]; Carpenter [715 h] | 59.31 | 11 | Civil | MB |
| C1C1111F5N630 |  | Base raft Zone-4 Concrete Casting column / inner wall | 2.5d | 2018-11-22 | 2018-11-24 | C1C1111F5N610 | 23.25d | 0d |  | Concrete Casting [25.83 CUM]; Helper [143 h]; Mason [429 h] | 40.21 | 11 | Civil | MB |
| C1C1111F5N640 |  | Base raft Zone-4 East Concrete Casting & Striking wall (2nd Lift) | 2.5d | 2018-11-25 | 2018-11-26 | C1C1111F5N630, C1C1111F5N600 | 23.25d | 2.5d |  | Concrete Casting [86.11 CUM]; Helper [143 h]; Mason [429 h] | 40.21 | 11 | Civil | MB |
| C1C1111F5N650 |  | Base raft Zone-4 West Concrete Casting & Striking wall (2nd Lift) | 2.5d | 2018-11-27 | 2018-11-28 | C1C1111F5N620, C1C1111F5N640 FF | 20.75d | 20d |  | Concrete Casting [86.11 CUM]; Helper [143 h]; Mason [429 h] | 40.21 | 11 | Civil | MB |

| ID | WBS | Activity | Duration | Start | Finish | Predecessors | Total float | Free float | Resources | Cost | MILESTONE | Discipline | LOCATION |
| --- | --- | --- | --- | --- | --- | --- | --- | --- | --- | --- | --- | --- | --- |
|  | 2 | **Outer & Inner Wall Zone 3** |  | 2018-11-19 | 2018-12-17 |  |  |  |  |  |  |  |  |
| C1C1111F5N660 |  | Base raft Zone-3 Waterproofing Wall (not by ZSCC) | 5d | 2018-11-19 | 2018-11-22 | C1C1111F5N380 | -7.5d | 0d |  |  | 10 | Civil | MB |
| C1C1111F5N670 |  | Base raft Zone-3 West Rebar fixing wall | 5d | 2018-11-24 | 2018-11-27 | C1C1111F5N530, C1C1111F5N660, C1C1111F5N380 | -7.5d | 0d | Helper [171.6 h]; Steel Fixer [572 h] | 52.27 | 10 | Civil | MB |
| C1C1111F5N680 |  | Base raft Zone-3 East Rebar fixing wall | 5d | 2018-11-24 | 2018-11-27 | C1C1111F5N670 SS | -7.5d | 0d | Helper [171.6 h]; Steel Fixer [572 h] | 52.27 | 10 | Civil | MB |
| C1C1111F5N690 |  | Base raft Zone-3 Rebar fixing column / inner wall | 5d | 2018-11-28 | 2018-12-02 | C1C1111F5N680 | -7.5d | 0d | Helper [171.6 h]; Steel Fixer [572 h] | 52.27 | 10 | Civil | MB |
| C1C1111F5N700 |  | Base raft Zone-3 East Formwork fixing wall (1st Lift ) | 5d | 2018-11-28 | 2018-12-02 | C1C1111F5N690 SS | -7.5d | 0d | Helper [143 h]; Carpenter [572 h] | 50.26 | 10 | Civil | MB |
| C1C1111F5N710 |  | Base raft Zone-3 West Formwork fixing wall ( 1st Lift ) | 5d | 2018-11-28 | 2018-12-02 | C1C1111F5N700 SS | -5d | 2.5d | Helper [143 h]; Carpenter [572 h] | 50.26 | 10 | Civil | MB |
| C1C1111F5N720 |  | Base raft Zone-3 East Concrete Casting & Striking wall ( 1st Lift ) | 2.5d | 2018-12-03 | 2018-12-04 | C1C1111F5N700 | -7.5d | 0d | Concrete Casting [174.38 CUM]; Mason [286 h]; Helper [143 h] | 30.16 | 10 | Civil | MB |
| C1C1111F5N730 |  | Base raft Zone-3 West Concrete Casting & Striking wall (1st Lift ) | 2.5d | 2018-12-05 | 2018-12-06 | C1C1111F5N710, C1C1111F5N720 | -7.5d | 0d | Mason [286 h]; Concrete Casting [174.38 CUM]; Helper [143 h] | 30.16 | 10 | Civil | MB |
| C1C1111F5N740 |  | Base raft Zone-3 East Formwork fixing wall (2nd Lift) | 6.25d | 2018-12-05 | 2018-12-10 | C1C1111F5N720 | 0.75d | 0d | Helper [214.5 h]; Carpenter [715 h] | 65.34 | 11 | Civil | MB |
| C1C1111F5N750 |  | Base raft Zone-3 Formwork fixing column / inner wall | 3.75d | 2018-12-08 | 2018-12-10 | C1C1111F5N740 FF | 0.75d | 0d | Helper [128.7 h]; Carpenter [429 h] | 39.21 | 11 | Civil | MB |
| C1C1111F5N760 |  | Base raft Zone-3 Concrete Casting column / inner wall | 2.5d | 2018-12-11 | 2018-12-12 | C1C1111F5N750 | 3.25d | 0d | Concrete Casting [10.76 CUM]; Helper [143 h]; Mason [429 h] | 40.21 | 11 | Civil | MB |
| C1C1111F5N770 |  | Base raft Zone-3 West Formwork fixing wall (2nd Lift) | 3.75d | 2018-12-12 | 2018-12-15 | C1C1111F5N750 FF+5d, C1C1111F5N730 | 0.75d | 0d | Helper [128.7 h]; Carpenter [429 h] | 39.21 | 11 | Civil | MB |
| C1C1111F5N780 |  | Base raft Zone-3 East Concrete Casting & Striking wall (2nd Lift) | 2.5d | 2018-12-13 | 2018-12-15 | C1C1111F5N760, C1C1111F5N740 | 3.25d | 2.5d | Concrete Casting [269.66 CUM]; Helper [143 h]; Mason [429 h] | 40.21 | 11 | Civil | MB |
| C1C1111F5N790 |  | Base raft Zone-3 West Concrete Casting & Striking wall (2nd Lift) | 2.5d | 2018-12-16 | 2018-12-17 | C1C1111F5N780 FF, C1C1111F5N770 | 0.75d | 0d | Concrete Casting [269.66 CUM]; Helper [143 h]; Mason [429 h] | 40.21 | 11 | Civil | MB |
|  | 3 | **Outer & Inner Wall Zone 2** |  | 2018-12-03 | 2018-12-24 |  |  |  |  |  |  |  |  |
| C1C1111F5N800 |  | Base raft Zone-2 Waterproofing Wall (not by ZSCC) | 5d | 2018-12-03 | 2018-12-06 | C1C1111F5N470 | -2.5d | 0d |  |  | 10 | Civil | MB |
| C1C1111F5N810 |  | Base raft Zone-2 Rebar fixing wall | 6.25d | 2018-12-08 | 2018-12-12 | C1C1111F5N800 | -2.5d | 0d | Helper [171.6 h]; Steel Fixer [715 h] | 62.32 | 10 | Civil | MB |
| C1C1111F5N820 |  | Base raft Zone-2 Rebar fixing column / inner wall | 6.25d | 2018-12-08 | 2018-12-12 | C1C1111F5N810 SS | -2.5d | 0d | Steel Fixer [715 h]; Helper [171.6 h] | 62.32 | 10 | Civil | MB |
| C1C1111F5N830 |  | Base raft Zone-2 Formwork fixing wall ( 1st Lift ) | 6.25d | 2018-12-08 | 2018-12-12 | C1C1111F5N820 SS | 0d | 2.5d | Helper [214.5 h]; Carpenter [715 h] | 65.34 | 10 | Civil | MB |
| C1C1111F5N840 |  | Base raft Zone-2 Formwork fixing column / inner wall | 5d | 2018-12-13 | 2018-12-17 | C1C1111F5N820 | -2.5d | 0d | Helper [171.6 h]; Carpenter [572 h] | 52.27 | 10 | Civil | MB |
| C1C1111F5N850 |  | Base raft Zone-2 Concrete Casting & Striking wall (1st Lift ) | 2.5d | 2018-12-16 | 2018-12-17 | C1C1111F5N830, C1C1111F5N840 FF | -2.5d | 0d | Helper [143 h]; Concrete Casting [134.83 CUM]; Mason [429 h] | 40.21 | 10 | Civil | MB |
| C1C1111F5N860 |  | Base raft Zone-2 Formwork fixing wall (2nd Lift) | 5d | 2018-12-18 | 2018-12-22 | C1C1111F5N850 | -2.5d | 0d | Helper [171.6 h]; Carpenter [572 h] | 52.27 | 11 | Civil | MB |
| C1C1111F5N870 |  | Base raft Zone-2 Concrete Casting column / inner wall | 2.5d | 2018-12-18 | 2018-12-19 | C1C1111F5N840 | 0d | 2.5d | Helper [143 h]; Concrete Casting [15.07 CUM]; Mason [429 h] | 40.21 | 11 | Civil | MB |
| C1C1111F5N880 |  | Base raft Zone-2 Concrete Casting & Striking wall (2nd Lift) | 2.5d | 2018-12-23 | 2018-12-24 | C1C1111F5N860, C1C1111F5N870, LOE-SUM1-150 FF | -2.5d | 0d | Concrete Casting [382.02 CUM]; Mason [429 h]; Helper [143 h] | 40.21 | 11 | Civil | MB |

| ID | WBS | Activity | Type | Duration | Start | Finish | Predecessors | Total float | Free float | Constraint | Calendar | Resources | Cost | MILESTONE | Discipline | LOCATION | AREA |
| --- | --- | --- | --- | --- | --- | --- | --- | --- | --- | --- | --- | --- | --- | --- | --- | --- | --- |
|  | 4 | **Outer & Inner Wall Zone 1** |  |  | 2018-11-25 | 2018-12-16 |  |  |  |  |  |  |  |  |  |  |  |
| C1C1111F5N890 |  | Base raft Zone-1 Waterproofing Wall (not by ZSCC) |  | 5d | 2018-11-25 | 2018-11-28 | C1C1111F5N510 | -10d | 0d |  |  |  |  | 10 | Civil | MB |  |
| C1C1111F5N900 |  | Base raft Zone-1 Rebar fixing wall |  | 6.25d | 2018-11-29 | 2018-12-04 | C1C1111F5N510, C1C1111F5N890 | -10d | 0d |  |  | Helper [171.6 h]; Steel Fixer [715 h] | 62.32 | 10 | Civil | MB |  |
| C1C1111F5N910 |  | Base raft Zone-1 Rebar fixing column / inner wall |  | 6.25d | 2018-11-29 | 2018-12-04 | C1C1111F5N900 SS | -10d | 0d |  |  | Helper [171.6 h]; Steel Fixer [715 h] | 62.32 | 10 | Civil | MB |  |
| C1C1111F5N920 |  | Base raft Zone-1 Formwork fixing wall ( 1st Lift ) |  | 6.25d | 2018-11-29 | 2018-12-04 | C1C1111F5N910 SS | -7.5d | 2.5d |  |  | Helper [143 h]; Carpenter [715 h] | 60.31 | 10 | Civil | MB |  |
| C1C1111F5N930 |  | Base raft Zone-1 Formwork fixing column / inner wall |  | 5d | 2018-12-05 | 2018-12-09 | C1C1111F5N910 | -10d | 0d |  |  | Helper [171.6 h]; Carpenter [572 h] | 52.27 | 11 | Civil | MB |  |
| C1C1111F5N940 |  | Base raft Zone-1 Concrete Casting & Striking wall (1st Lift ) |  | 2.5d | 2018-12-08 | 2018-12-09 | C1C1111F5N920, C1C1111F5N930 FF | -10d | 0d |  |  | Mason [429 h]; Concrete Casting [274.49 CUM]; Helper [143 h] | 40.21 | 10 | Civil | MB |  |
| C1C1111F5N950 |  | Base raft Zone-1 Formwork fixing wall (2nd Lift) |  | 5d | 2018-12-10 | 2018-12-13 | C1C1111F5N940 | 6.25d | 0d |  |  | Carpenter [572 h]; Helper [128.7 h] | 49.26 | 11 | Civil | MB |  |
| C1C1111F5N960 |  | Base raft Zone-1 Concrete Casting column / inner wall |  | 2.5d | 2018-12-10 | 2018-12-11 | C1C1111F5N930 | 8.75d | 2.5d |  |  | Concrete Casting [20.45 CUM]; Mason [429 h]; Helper [143 h] | 40.21 | 11 | Civil | MB |  |
| C1C1111F5N970 |  | Base raft Zone-1 Concrete Casting & Striking wall (2nd Lift) |  | 2.5d | 2018-12-15 | 2018-12-16 | C1C1111F5N950, C1C1111F5N960, LOE-SUM1-150 FF | 6.25d | 8.75d |  |  | Concrete Casting [449.44 CUM]; Mason [429 h]; Helper [143 h] | 40.21 | 11 | Civil | MB |  |
|  | 4 | **North - 1st Stage Concrete on TRACK ACCESS LINE** |  |  | 2018-11-26 | 2018-12-09 |  |  |  |  |  |  |  |  |  |  |  |
| C1C1111F5N980 |  | MS1F5 - 1st stage Concrete at P07- Zone-3 & 4 |  | 12.5d | 2018-11-26 | 2018-12-06 | C1C1111F5N590, C1C1111F5N580, C1C1111F5C835, C1C1111F5N730 FF, C1C1111F5N720 FF | -7.5d | 2.5d |  |  | Mason [750 h]; Concrete Casting [176.18 CUM]; Helper [286 h]; Carpenter [650 h]; Steel Fixer [650 h] | 164.24 | 10 | Civil | MB |  |
| C1C1111F5N990 |  | MS1F5 - 1st stage Concrete at P07- Zone-1 & 2 |  | 12.5d | 2018-11-28 | 2018-12-09 | C1C1111F5N910 FF, C1C1111F5N980 FF, C1C1111F5N940 FF | -10d | 0d | finish on or before 2018-11-30 |  | Mason [750 h]; Concrete Casting [204.04 CUM]; Helper [286 h]; Carpenter [650 h]; Steel Fixer [650 h] | 164.24 | 10 | Civil | MB |  |
|  | 5 | **Platform Level (P06 ) North ( AREA-2 & AREA-1 )** |  |  | 2018-12-18 | 2019-01-17 |  |  |  |  |  |  |  |  |  |  |  |
| LOE-SUM1-160 |  | North . B01 - Concrete Works | level of effort | 33.75d | 2018-12-18 | 2019-01-17 | C1C1111F5N1000 SS | -2.5d | 0d |  | Saudi |  |  |  | Civil |  |  |
|  | 1 | **Platform Level ( P06 . AREA-2, 27.2. L , 523 m3 )** |  |  | 2018-12-18 | 2019-01-10 |  |  |  |  |  |  |  |  |  |  |  |
| C1C1111F5N1000 |  | P06- AREA-2 Formwork and Slab fixing |  | 7.5d | 2018-12-18 | 2018-12-24 | C1C1111F5C850, C1C1111F5N650, C1C1111F5N790 | 0.75d | 0d |  |  | Helper [343.2 h]; Carpenter [686.4 h] | 72.38 | 11 | Civil | MB | 2 |
| C1C1111F5N1010 |  | P06- AREA-2 Rebar fixing |  | 6.25d | 2018-12-25 | 2018-12-30 | C1C1111F5N1000 | 0.75d | 0d |  |  | Helper [286 h]; Steel Fixer [715 h] | 70.37 | 11 | Civil | MB | 2 |
| C1C1111F5N1020 |  | P06- AREA-2 Concrete Casting Slab |  | 2.5d | 2018-12-31 | 2019-01-01 | C1C1111F5N1010 | 0.75d | 0d |  |  | Helper [143 h]; Concrete Casting [240 CUM]; Mason [572 h] | 50.26 | 11 | Civil | MB | 2 |
| C1C1111F5N1030 |  | P06- AREA-2 Rebar fixing column / inner wall |  | 3.75d | 2019-01-02 | 2019-01-05 | C1C1111F5N1020 | 0.75d | 0d |  |  | Helper [286 h]; Steel Fixer [429 h] | 50.27 | 11 | Civil | MB | 2 |
| C1C1111F5N1040 |  | P06- AREA-2 Formwork fixing column / inner wall |  | 3.75d | 2019-01-06 | 2019-01-08 | C1C1111F5N1030 | 0.75d | 0d |  |  | Helper [257.4 h]; Carpenter [686.4 h] | 66.35 | 11 | Civil | MB | 2 |
| C1C1111F5N1050 |  | P06-AREA-2 Concrete Casting column / inner wall |  | 2.5d | 2019-01-09 | 2019-01-10 | C1C1111F5N1040 | 0.75d | 0d |  |  | Concrete Casting [174.38 CUM]; Helper [143 h]; Mason [429 h] | 40.21 | 11 | Civil | MB | 2 |
|  | 2 | **Platform Level ( P06 . AREA-1, 27.2. L , 523 m3 )** |  |  | 2018-12-25 | 2019-01-17 |  |  |  |  |  |  |  |  |  |  |  |
| C1C1111F5N1060 |  | P06- AREA-1 Formwork and Slab fixing |  | 7.5d | 2018-12-25 | 2018-12-31 | C1C1111F5N970, C1C1111F5N880, C1C1111F5N950, C1C1111F5S800 SS | -2.5d | 0d |  |  | Helper [343.2 h]; Carpenter [686.4 h] | 72.38 | 11 | Civil | MB | 1 |
| C1C1111F5N1070 |  | P06- AREA-1 Rebar fixing |  | 6.25d | 2019-01-01 | 2019-01-06 | C1C1111F5N1060 | -2.5d | 0d |  |  | Steel Fixer [715 h]; Helper [286 h] | 70.37 | 11 | Civil | MB | 1 |
| C1C1111F5N1080 |  | P06- AREA-1 Concrete Casting Slab |  | 2.5d | 2019-01-07 | 2019-01-08 | C1C1111F5N1070 | -2.5d | 0d |  |  | Helper [143 h]; Mason [572 h]; Concrete Casting [87.84 CUM] | 50.26 | 11 | Civil | MB | 1 |
| C1C1111F5N1090 |  | P06- AREA-1 Rebar fixing column / inner wall |  | 3.75d | 2019-01-09 | 2019-01-12 | C1C1111F5N1080 | -2.5d | 0d |  |  | Steel Fixer [429 h]; Helper [286 h] | 50.27 | 11 | Civil | MB | 1 |
| C1C1111F5N1100 |  | P06- AREA-1 Formwork fixing column / inner wall |  | 3.75d | 2019-01-13 | 2019-01-15 | C1C1111F5N1090 | -2.5d | 0d |  |  | Carpenter [686.4 h]; Helper [257.4 h] | 66.35 | 11 | Civil | MB | 1 |
| C1C1111F5N1110 |  | P06-AREA-1 Concrete Casting column / inner wall |  | 2.5d | 2019-01-16 | 2019-01-17 | C1C1111F5N1100, LOE-SUM1-160 FF | -2.5d | 0d |  |  | Helper [143 h]; Mason [429 h]; Concrete Casting [30.74 CUM] | 40.21 | 11 | Civil | MB | 1 |

| ID | WBS | Activity | Type | Duration | Start | Finish | Predecessors | Total float | Free float | Calendar | Resources | Cost | Discipline | MILESTONE | AREA | LOCATION |
| --- | --- | --- | --- | --- | --- | --- | --- | --- | --- | --- | --- | --- | --- | --- | --- | --- |
|  | 6 | **Mezzanine Level North ( AREA-2 & AREA-1 )** |  |  | 2019-01-12 | 2019-02-14 |  |  |  |  |  |  |  |  |  |  |
| LOE-SUM1-170 |  | North . B01 - Concrete Works | level of effort | 37.5d | 2019-01-12 | 2019-02-14 | C1C1111F5N1120 SS | -0.5d | 0d | Saudi |  |  | Civil |  |  |  |
|  | 1 | **Mezzanine Level ( B05 . AREA-2 )** |  |  | 2019-01-12 | 2019-02-13 |  |  |  |  |  |  |  |  |  |  |
| C1C1111F5N1120 |  | B05 - AREA-2 SE Formwork and Slab fixing |  | 5d | 2019-01-12 | 2019-01-15 | C1C1111F5N1050 | 0.75d | 0d |  | Carpenter [686.4 h]; Helper [343.2 h] | 72.38 | Civil | 11 | 2 | MB |
| C1C1111F5N1130 |  | B05 - AREA-2 SW Formwork and Slab fixing |  | 5d | 2019-01-12 | 2019-01-15 | C1C1111F5N1120 SS | 0.75d | 0d |  | Carpenter [686.4 h]; Helper [343.2 h] | 72.38 | Civil | 11 | 2 | MB |
| C1C1111F5N1140 |  | B05 - AREA-2 SE Rebar fixing |  | 5d | 2019-01-14 | 2019-01-17 | C1C1111F5N1130 SS+2.5d, C1C1111F5N1120 SS+2.5d | 0.75d | 0d |  | Steel Fixer [858 h]; Helper [343.2 h] | 84.45 | Civil | 11 | 2 | MB |
| C1C1111F5N1150 |  | B05 - AREA-2 SW Rebar fixing |  | 5d | 2019-01-14 | 2019-01-17 | C1C1111F5N1130 SS+2.5d | 0.75d | 0d |  | Steel Fixer [858 h]; Helper [343.2 h] | 84.45 | Civil | 11 | 2 | MB |
| C1C1111F5N1160 |  | B05 - AREA-2 SE Concrete Casting Slab |  | 2.5d | 2019-01-19 | 2019-01-20 | C1C1111F5N1140, C1C1111F5N1150 SS+1.25d | 0.75d | 0d |  | Concrete Casting [7.75 CUM]; Mason [572 h]; Helper [114.4 h] | 48.25 | Civil | 11 | 2 | MB |
| C1C1111F5N1170 |  | B05 - AREA-2 SW Concrete Casting Slab |  | 2.5d | 2019-01-19 | 2019-01-20 | C1C1111F5N1150, C1C1111F5N1150 FF | 0.75d | 0d |  | Concrete Casting [8.07 CUM]; Helper [114.4 h]; Mason [572 h] | 48.25 | Civil | 11 | 2 | MB |
|  | 1 | **Mezzanine Level ( B05 AREA-2 . Walls )** |  |  | 2019-01-21 | 2019-02-10 |  |  |  |  |  |  |  |  |  |  |
| C1C1111F5N1180 |  | B05- AREA-2 Rebar fixing column |  | 5d | 2019-01-21 | 2019-01-24 | C1C1111F5N1170 SS+2.5d | 8.25d | 0d |  | Steel Fixer [572 h]; Helper [228.8 h] | 56.29 | Civil | 11 | 2 | MB |
| C1C1111F5N1190 |  | B05- AREA-2 Waterproofing wall (not by ZSCC) |  | 6.25d | 2019-01-21 | 2019-01-26 | C1C1111F5N1160, C1C1111F5N1170 | 0.75d | 0d |  |  |  | Civil | 11 | 2 | MB |
| C1C1111F5N1200 |  | B05- AREA-2 Formwork fixing column / inner wall |  | 5d | 2019-01-26 | 2019-01-29 | C1C1111F5N1180 | 8.25d | 0d |  | Carpenter [343.2 h]; Helper [228.8 h] | 40.21 | Civil | 11 | 2 | MB |
| C1C1111F5N1210 |  | B05- AREA-2 Rebar fixing wall |  | 6.25d | 2019-01-28 | 2019-02-02 | C1C1111F5N1190 FF+7.5d | 0.75d | 0d |  | Steel Fixer [1001 h]; Helper [400.4 h] | 98.52 | Civil | 11 | 2 | MB |
| C1C1111F5N1220 |  | B05- AREA-2 Concrete Casting column / inner wall |  | 2.5d | 2019-01-30 | 2019-01-31 | C1C1111F5N1200 | 8.25d | 7.5d |  | Concrete Casting [165 CUM]; Helper [143 h]; Mason [429 h] | 40.21 | Civil | 11 | 2 | MB |
| C1C1111F5N1230 |  | B05- AREA-2 Formwork fixing wall |  | 7.5d | 2019-02-02 | 2019-02-07 | C1C1111F5N1210 FF+6.25d | 0.75d | 0d |  | Carpenter [1001 h]; Helper [400.4 h] | 98.52 | Civil | 11 | 2 | MB |
| C1C1111F5N1240 |  | B05- AREA-2 Concrete Casting & Striking wall |  | 2.5d | 2019-02-09 | 2019-02-10 | C1C1111F5N1230, C1C1111F5N1220 | 0.75d | 0d |  | Concrete Casting [205.6 CUM]; Helper [143 h]; Mason [429 h] | 40.21 | Civil | 11 | 2 | MB |
|  | 4 | **Mezzanine Level ( B05 . OTE AREA--2)** |  |  | 2019-01-16 | 2019-02-13 |  |  |  |  |  |  |  |  |  |  |
|  | 3 | **Mezzanine Level ( B05 . OTE AREA-2) Lower Part** |  |  | 2019-01-16 | 2019-01-30 |  |  |  |  |  |  |  |  |  |  |
| C1C1111F5N1250 |  | B05- AREA-2 Formwork |  | 7.5d | 2019-01-16 | 2019-01-22 | C1C1111F5N1120, C1C1111F5N980 | 0.75d | 0d |  | Helper [480 h]; Carpenter [840 h] | 92.79 | Civil | 11 | 2 | MB |
| C1C1111F5N1260 |  | B05-AREA-2 Rebar fixing |  | 6.25d | 2019-01-23 | 2019-01-28 | C1C1111F5N1250 | 0.75d | 0d |  | Helper [400 h]; Steel Fixer [750 h] | 80.85 | Civil | 11 | 2 | MB |
| C1C1111F5N1270 |  | B05-AREA-2 Concrete Casting Slab |  | 2.5d | 2019-01-29 | 2019-01-30 | C1C1111F5N1260 | 0.75d | 0d |  | Concrete Casting [72.66 CUM]; Helper [114.4 h]; Mason [171.6 h] | 20.1 | Civil | 11 | 2 | MB |
|  | 1 | **Mezzanine Level ( B05 . OTE AREA-2) Upper Part** |  |  | 2019-01-31 | 2019-02-13 |  |  |  |  |  |  |  |  |  |  |
| C1C1111F5N1280 |  | B05- AREA-2 Formwork |  | 6.25d | 2019-01-31 | 2019-02-05 | C1C1111F5N1270 | 0.75d | 0d |  | Helper [500 h]; Carpenter [750 h] | 87.88 | Civil | 11 | 2 | MB |
| C1C1111F5N1290 |  | B05-AREA-2 Rebar fixing |  | 6.25d | 2019-02-06 | 2019-02-11 | C1C1111F5N1280 | 0.75d | 0d |  | Helper [500 h]; Steel Fixer [750 h] | 87.88 | Civil | 11 | 2 | MB |
| C1C1111F5N1300 |  | B05-AREA-2 Concrete Casting Slab |  | 2.5d | 2019-02-12 | 2019-02-13 | C1C1111F5N1290, LOE-SUM1-170 FF | 0.75d | 0d |  | Concrete Casting [91 CUM]; Helper [114.4 h]; Mason [171.6 h] | 20.1 | Civil | 11 | 2 | MB |

| ID | WBS | Activity | Type | Duration | Start | Finish | Predecessors | Total float | Free float | Calendar | Resources | Cost | MILESTONE | Discipline | AREA | LOCATION |
| --- | --- | --- | --- | --- | --- | --- | --- | --- | --- | --- | --- | --- | --- | --- | --- | --- |
|  | 2 | **Mezzanine Level ( B05 . AREA-1 )** |  |  | 2019-01-19 | 2019-02-14 |  |  |  |  |  |  |  |  |  |  |
| C1C1111F5N1310 |  | B05 - AREA-1 SE Formwork and Slab fixing |  | 5d | 2019-01-19 | 2019-01-22 | C1C1111F5N1110 | -2.5d | 0d |  | Helper [343.2 h]; Carpenter [686.4 h] | 72.38 | 11 | Civil | 1 | MB |
| C1C1111F5N1320 |  | B05 - AREA-1 SW Formwork and Slab fixing |  | 5d | 2019-01-19 | 2019-01-22 | C1C1111F5N1310 SS | -2.5d | 0d |  | Helper [343.2 h]; Carpenter [686.4 h] | 72.38 | 11 | Civil | 1 | MB |
| C1C1111F5N1330 |  | B05 - AREA-1 SE Rebar fixing |  | 5d | 2019-01-21 | 2019-01-24 | C1C1111F5N1310 SS+2.5d, C1C1111F5N1320 SS+2.5d | -2.5d | 0d |  | Helper [343.2 h]; Steel Fixer [858 h] | 84.45 | 11 | Civil | 1 | MB |
| C1C1111F5N1340 |  | B05 - AREA-1 SW Rebar fixing |  | 5d | 2019-01-21 | 2019-01-24 | C1C1111F5N1320 SS+2.5d | -2.5d | 0d |  | Helper [343.2 h]; Steel Fixer [858 h] | 84.45 | 11 | Civil | 1 | MB |
| C1C1111F5N1350 |  | B05 - AREA-1 SE Concrete Casting Slab |  | 2.5d | 2019-01-26 | 2019-01-27 | C1C1111F5N1330, C1C1111F5N1340 SS+1.25d | -2.5d | 0d |  | Concrete Casting [71.8 CUM]; Helper [114.4 h]; Mason [572 h] | 48.25 | 11 | Civil | 1 | MB |
| C1C1111F5N1360 |  | B05 - AREA-1 SW Concrete Casting Slab |  | 2.5d | 2019-01-26 | 2019-01-27 | C1C1111F5N1340, C1C1111F5N1340 FF | -2.5d | 0d |  | Concrete Casting [71.8 CUM]; Helper [114.4 h]; Mason [572 h] | 48.25 | 11 | Civil | 1 | MB |
|  | 1 | **Mezzanine Level ( B05 AREA-1 . Walls )** |  |  | 2019-01-28 | 2019-02-14 |  |  |  |  |  |  |  |  |  |  |
| C1C1111F5N1370 |  | B05- AREA-1 Rebar fixing column / inner wall |  | 5d | 2019-01-28 | 2019-01-31 | C1C1111F5N1360 SS+2.5d | 2.5d | 0d |  | Helper [228.8 h]; Steel Fixer [572 h] | 56.29 | 11 | Civil | 1 | MB |
| C1C1111F5N1380 |  | B05- AREA-1 Waterproofing wall (not by ZSCC) |  | 5d | 2019-01-28 | 2019-01-31 | C1C1111F5N1350, C1C1111F5N1360 | -2.5d | 0d |  |  |  | 11 | Civil | 1 | MB |
| C1C1111F5N1400 |  | B05- AREA-1 Rebar fixing wall |  | 7.5d | 2019-01-31 | 2019-02-06 | C1C1111F5N1380 FF+6.25d | -2.5d | 0d |  | Helper [400.4 h]; Steel Fixer [900 h] | 91.42 | 11 | Civil | 1 | MB |
| C1C1111F5N1390 |  | B05- AREA-1 Formwork fixing column / inner wall |  | 5d | 2019-02-02 | 2019-02-05 | C1C1111F5N1370 | 2.5d | 0d |  | Helper [228.8 h]; Carpenter [343.2 h] | 40.21 | 11 | Civil | 1 | MB |
| C1C1111F5N1410 |  | B05- AREA-1 Formwork fixing wall |  | 7.5d | 2019-02-06 | 2019-02-12 | C1C1111F5N1400 FF+6.25d | -2.5d | 0d |  | Helper [400.4 h]; Carpenter [900 h] | 91.42 | 11 | Civil | 1 | MB |
| C1C1111F5N1420 |  | B05- AREA-1 Concrete Casting column / inner wall |  | 2.5d | 2019-02-06 | 2019-02-07 | C1C1111F5N1390 | 2.5d | 5d |  | Concrete Casting [269.1 CUM]; Helper [143 h]; Mason [429 h] | 40.21 | 11 | Civil | 1 | MB |
| C1C1111F5N1430 |  | B05- AREA-1 Concrete Casting & Striking wall |  | 2.5d | 2019-02-13 | 2019-02-14 | C1C1111F5N1410, C1C1111F5N1420, LOE-SUM1-170 FF | -2.5d | 0d |  | Concrete Casting [243.27 CUM]; Helper [143 h]; Mason [429 h] | 40.21 | 11 | Civil | 1 | MB |
|  | 7 | **Technical Level (B-04 ) North ( AREA-2 & AREA-1)** |  |  | 2019-02-11 | 2019-03-25 |  |  |  |  |  |  |  |  |  |  |
| LOE-SUM1-180 |  | North . B01 - Concrete Works | level of effort | 46.25d | 2019-02-11 | 2019-03-25 | C1C1111F5N1500 SS | 0.75d | 0d | Saudi |  |  |  | Civil |  |  |
|  | 2 | **Technical Level (B-04 . AREA-2)** |  |  | 2019-02-11 | 2019-03-20 |  |  |  |  |  |  |  |  |  |  |
| C1C1111F5N1500 |  | B04- AREA-2 Formwork and Slab fixing |  | 7.5d | 2019-02-11 | 2019-02-17 | C1C1111F5N1240, C1C1111F5N1300 FF+3.75d, C1C1111F5N1170 | 0.75d | 0d |  | Helper [343.2 h]; Carpenter [686.4 h] | 72.38 | 11 | Civil | 2 | MB |
| C1C1111F5N1510 |  | B04 - AREA-2 Rebar fixing |  | 7.5d | 2019-02-18 | 2019-02-24 | C1C1111F5N1500, B530 FS+32.5d | 0.75d | 0d |  | Helper [343.2 h]; Steel Fixer [858 h] | 84.45 | 11 | Civil | 2 | MB |
| C1C1111F5N1520 |  | B04- AREA-2 Technical Concrete Casting Slab |  | 2.5d | 2019-02-25 | 2019-02-26 | C1C1111F5N1510 | 0.75d | 0d |  | Concrete Casting [247.58 CUM]; Helper [114.4 h]; Mason [572 h] | 48.25 | 11 | Civil | 2 | MB |
|  | 1 | **Technical Level (B-04 AREA-2 .Walls)** |  |  | 2019-02-27 | 2019-03-20 |  |  |  |  |  |  |  |  |  |  |
| C1C1111F5N1530 |  | B04- AREA-2 Rebar fixing column |  | 5d | 2019-02-27 | 2019-03-03 | C1C1111F5N1520 | 9.5d | 0d |  | Helper [228.8 h]; Steel Fixer [572 h] | 56.29 | 12 | Civil | 2 | MB |
| C1C1111F5N1540 |  | B04- AREA-2 Waterproofing wall (not by ZSCC) |  | 7.5d | 2019-02-27 | 2019-03-05 | C1C1111F5N1520 | 0.75d | 0d |  |  |  | 12 | Civil | 2 | MB |
| C1C1111F5N1550 |  | B04- AREA-2 Formwork fixing column |  | 5d | 2019-03-04 | 2019-03-07 | C1C1111F5N1530 | 9.5d | 0d |  | Helper [286 h]; Carpenter [457.6 h] | 52.28 | 12 | Civil | 2 | MB |
| C1C1111F5N1560 |  | B04- AREA-2 Rebar fixing wall / inner wall |  | 7.5d | 2019-03-06 | 2019-03-12 | C1C1111F5N1540 | 0.75d | 0d |  | Helper [343.2 h]; Steel Fixer [686.4 h] | 72.38 | 12 | Civil | 2 | MB |
| C1C1111F5N1580 |  | B04- AREA-2 Concrete Casting column |  | 2.5d | 2019-03-09 | 2019-03-10 | C1C1111F5N1550 | 9.5d | 8.75d |  | Concrete Casting [296.01 CUM]; Helper [171.6 h]; Mason [429 h] | 42.22 | 12 | Civil | 2 | MB |
| C1C1111F5N1570 |  | B04- AREA-2 Formwork fixing wall / inner wall |  | 7.5d | 2019-03-12 | 2019-03-18 | C1C1111F5N1560 FF+6.25d | 0.75d | 0d |  | Helper [343.2 h]; Carpenter [686.4 h] | 72.38 | 12 | Civil | 2 | MB |
| C1C1111F5N1590 |  | B04- AREA-2 Concrete Casting & Striking wall |  | 2.5d | 2019-03-19 | 2019-03-20 | C1C1111F5N1580, C1C1111F5N1570, LOE-SUM1-180 FF | 0.75d | 0d |  | Concrete Casting [287.4 CUM]; Helper [171.6 h]; Mason [429 h] | 42.22 | 12 | Civil | 2 | MB |

| ID | WBS | Activity | Type | Duration | Start | Finish | Predecessors | Total float | Free float | Calendar | Resources | Cost | MILESTONE | Discipline | AREA | LOCATION |
| --- | --- | --- | --- | --- | --- | --- | --- | --- | --- | --- | --- | --- | --- | --- | --- | --- |
|  | 1 | **Technical Level (B-04 . AREA-1)** |  |  | 2019-02-16 | 2019-03-25 |  |  |  |  |  |  |  |  |  |  |
| C1C1111F5N1600 |  | B04- AREA-1 Formwork and Slab fixing |  | 7.5d | 2019-02-16 | 2019-02-21 | C1C1111F5N1430 | -2.5d | 0d |  | Helper [343.2 h]; Carpenter [686.4 h] | 72.38 | 12 | Civil | 1 | MB |
| C1C1111F5N1610 |  | B04 - AREA-1 Rebar fixing |  | 7.5d | 2019-02-23 | 2019-02-28 | B540 FS+32.5d, C1C1111F5N1600 | -2.5d | 0d |  | Helper [343.2 h]; Steel Fixer [858 h] | 84.45 | 12 | Civil | 1 | MB |
| C1C1111F5N1620 |  | B04- AREA-1 Technical Concrete Casting Slab |  | 2.5d | 2019-03-02 | 2019-03-03 | C1C1111F5N1610 | -2.5d | 0d |  | Concrete Casting [389.49 CUM]; Helper [114.4 h]; Mason [572 h] | 48.25 | 12 | Civil | 1 | MB |
|  | 1 | **Technical Level (B-04 AREA-1 .Walls)** |  |  | 2019-03-04 | 2019-03-25 |  |  |  |  |  |  |  |  |  |  |
| C1C1111F5N1630 |  | B04- AREA-1 Rebar fixing column / inner wall |  | 5d | 2019-03-04 | 2019-03-07 | C1C1111F5N1620 | 9.5d | 0d |  | Helper [228.8 h]; Steel Fixer [572 h] | 56.29 | 12 | Civil | 1 | MB |
| C1C1111F5N1640 |  | B04- AREA-1 Waterproofing wall (not by ZSCC) |  | 7.5d | 2019-03-04 | 2019-03-10 | C1C1111F5N1620 | 0.75d | 0d |  |  |  | 12 | Civil | 1 | MB |
| C1C1111F5N1650 |  | B04- AREA-1 Formwork fixing column / inner wall |  | 5d | 2019-03-09 | 2019-03-12 | C1C1111F5N1630 | 9.5d | 0d |  | Helper [286 h]; Carpenter [457.6 h] | 52.28 | 12 | Civil | 1 | MB |
| C1C1111F5N1660 |  | B04- AREA-1 Rebar fixing wall |  | 7.5d | 2019-03-11 | 2019-03-17 | C1C1111F5N1640 | 0.75d | 0d |  | Helper [343.2 h]; Steel Fixer [686.4 h] | 72.38 | 12 | Civil | 1 | MB |
| C1C1111F5N1670 |  | B04- AREA-1 Concrete Casting column / inner wall |  | 2.5d | 2019-03-13 | 2019-03-14 | C1C1111F5N1650 | 9.5d | 8.75d |  | Mason [429 h]; Concrete Casting [486.54 CUM]; Helper [171.6 h] | 42.22 | 12 | Civil | 1 | MB |
| C1C1111F5N1680 |  | B04- AREA-1 Formwork fixing wall |  | 7.5d | 2019-03-17 | 2019-03-23 | C1C1111F5N1660 FF+6.25d | 0.75d | 0d |  | Helper [343.2 h]; Carpenter [686.4 h] | 72.38 | 12 | Civil | 1 | MB |
| C1C1111F5N1690 |  | B04- AREA-1 Concrete Casting & Striking wall |  | 2.5d | 2019-03-24 | 2019-03-25 | C1C1111F5N1680, C1C1111F5N1670, LOE-SUM1-180 FF | 0.75d | 0d |  | Concrete Casting [453.17 CUM]; Helper [171.6 h]; Mason [429 h] | 42.22 | 12 | Civil | 1 | MB |
|  | 8 | **Concourse Level B03 North ( AREA-2 & AREA-1 )** |  |  | 2019-03-21 | 2019-04-27 |  |  |  |  |  |  |  |  |  |  |
| LOE-SUM1-190 |  | North . B01 - Concrete Works | level of effort | 40d | 2019-03-21 | 2019-04-27 | C1C1111F5N1700 SS | 0.75d | 0d | Saudi |  |  |  | Civil |  |  |
|  | 1 | **Concourse Level ( B03 . AREA-2 )** |  |  | 2019-03-21 | 2019-04-22 |  |  |  |  |  |  |  |  |  |  |
| C1C1111F5N1700 |  | B03- AREA-2 Formwork and Slab fixing |  | 6.25d | 2019-03-21 | 2019-03-26 | C1C1111F5N1590 | 0.75d | 0d |  | Helper [343.2 h]; Carpenter [686.4 h] | 72.38 | 12 | Civil | 2 | MB |
| C1C1111F5N1710 |  | B03- AREA-2 Rebar fixing |  | 6.25d | 2019-03-27 | 2019-04-01 | C1C1111F5N1700, B580 FS+32.5d | 0.75d | 0d |  | Helper [343.2 h]; Steel Fixer [715 h] | 74.39 | 12 | Civil | 2 | MB |
| C1C1111F5N1720 |  | B03- AREA-2 Concrete Casting Slab |  | 2.5d | 2019-04-02 | 2019-04-03 | C1C1111F5N1710 | 0.75d | 0d |  | Concrete Casting [209.15 CUM]; Helper [143 h]; Mason [572 h] | 50.26 | 12 | Civil | 2 | MB |
| C1C1111F5N1730 |  | B03- AREA-2 Waterproofing wall (not by ZSCC) |  | 6.25d | 2019-04-04 | 2019-04-09 | C1C1111F5N1720 | 0.75d | 0d |  |  |  | 12 | Civil | 2 | MB |
| C1C1111F5N1740 |  | B03- AREA-2 Rebar fixing wall / column / staircase |  | 6.25d | 2019-04-10 | 2019-04-15 | C1C1111F5N1730 | 0.75d | 0d |  | Helper [457.6 h]; Steel Fixer [572 h] | 72.38 | 12 | Civil | 2 | MB |
| C1C1111F5N1750 |  | B03- AREA-2 Formwork fixing wall / column / staircase |  | 6.25d | 2019-04-15 | 2019-04-20 | C1C1111F5N1740 SS+5d | 0.75d | 0d |  | Helper [457.6 h]; Carpenter [572 h] | 72.38 | 12 | Civil | 2 | MB |
| C1C1111F5N1760 |  | B03- AREA-2 Concrete Casting wall / column / staircase |  | 2.5d | 2019-04-21 | 2019-04-22 | C1C1111F5N1750 | 0.75d | 0d |  | Concrete Casting [297.41 CUM]; Helper [143 h]; Mason [429 h] | 40.21 | 12 | Civil | 2 | MB |
|  | 2 | **Concourse Level ( B03 . AREA-1 )** |  |  | 2019-03-26 | 2019-04-27 |  |  |  |  |  |  |  |  |  |  |
| C1C1111F5N1770 |  | B03- AREA-1 Formwork and Slab fixing |  | 6.25d | 2019-03-26 | 2019-03-31 | C1C1111F5N1690 | 0.75d | 0d |  | Helper [343.2 h]; Carpenter [686.4 h] | 72.38 | 12 | Civil | 1 | MB |
| C1C1111F5N1780 |  | B03- AREA-1 Rebar fixing |  | 6.25d | 2019-04-01 | 2019-04-06 | B590 FS+32.5d, C1C1111F5N1770 | 0.75d | 0d |  | Helper [343.2 h]; Steel Fixer [715 h] | 74.39 | 12 | Civil | 1 | MB |
| C1C1111F5N1790 |  | B03- AREA-1 Concrete Casting Slab |  | 2.5d | 2019-04-07 | 2019-04-08 | C1C1111F5N1780 | 0.75d | 0d |  | Concrete Casting [465.55 CUM]; Helper [143 h]; Mason [572 h] | 50.26 | 12 | Civil | 1 | MB |
| C1C1111F5N1800 |  | B03- AREA-1 Waterproofing wall (not by ZSCC) |  | 6.25d | 2019-04-09 | 2019-04-14 | C1C1111F5N1790 | 0.75d | 0d |  |  |  | 12 | Civil | 1 | MB |
| C1C1111F5N1810 |  | B03- AREA-1 Rebar fixing wall / column / staircase |  | 6.25d | 2019-04-15 | 2019-04-20 | C1C1111F5N1800 | 0.75d | 0d |  | Helper [457.6 h]; Steel Fixer [643.5 h] | 77.41 | 12 | Civil | 1 | MB |
| C1C1111F5N1820 |  | B03- AREA-1 Formwork fixing wall / column / staircase |  | 6.25d | 2019-04-20 | 2019-04-24 | C1C1111F5N1810 SS+5d | 0.75d | 0d |  | Helper [457.6 h]; Carpenter [643.5 h] | 77.41 | 12 | Civil | 1 | MB |
| C1C1111F5N1830 |  | B03- AREA-1 Concrete Casting wall / column / staircase |  | 2.5d | 2019-04-25 | 2019-04-27 | C1C1111F5N1820, LOE-SUM1-190 FF | 0.75d | 0d |  | Concrete Casting [362 CUM]; Helper [143 h]; Mason [429 h] | 40.21 | 12 | Civil | 1 | MB |

| ID | WBS | Activity | Type | Duration | Start | Finish | Predecessors | Total float | Free float | Calendar | Resources | Cost | Discipline | MILESTONE | AREA | LOCATION |
| --- | --- | --- | --- | --- | --- | --- | --- | --- | --- | --- | --- | --- | --- | --- | --- | --- |
|  | 9 | **TV Louver Level B02 North ( AREA-2 & AREA-1 )** |  |  | 2019-04-23 | 2019-05-29 |  |  |  |  |  |  |  |  |  |  |
| LOE-SUM1-200 |  | North . B01 - Concrete Works | level of effort | 40d | 2019-04-23 | 2019-05-29 | C1C1111F5N1880 SS | 0.75d | 0d | Saudi |  |  | Civil |  |  |  |
|  | 1 | **TV Louver Level ( B02 . AREA-2 )** |  |  | 2019-04-23 | 2019-05-05 |  |  |  |  |  |  |  |  |  |  |
| C1C1111F5N1880 |  | B02- AREA-2 Rebar fixing wall / column / staircase |  | 6.25d | 2019-04-23 | 2019-04-28 | C1C1111F5N1760, B630 FS+32.5d | 0.75d | 0d |  | Helper [457.6 h]; Steel Fixer [750 h] | 84.9 | Civil | 12 | 2 | MB |
| C1C1111F5N1890 |  | B02- AREA-2 Formwork fixing wall / column / staircase |  | 6.25d | 2019-04-28 | 2019-05-02 | C1C1111F5N1880 SS+5d | 0.75d | 0d |  | Helper [457.6 h]; Carpenter [750 h] | 84.9 | Civil | 12 | 2 | MB |
| C1C1111F5N1900 |  | B02- AREA-2 Concrete Casting wall / column / staircase |  | 2.5d | 2019-05-04 | 2019-05-05 | C1C1111F5N1890 | 0.75d | 0d |  | Concrete Casting [230.03 CUM]; Helper [143 h]; Mason [429 h] | 40.21 | Civil | 12 | 2 | MB |
|  | 2 | **TV Louver Level ( B02 . AREA-1 )** |  |  | 2019-04-28 | 2019-05-29 |  |  |  |  |  |  |  |  |  |  |
| C1C1111F5N1910 |  | B02- AREA-1 Formwork and Slab fixing |  | 6.25d | 2019-04-28 | 2019-05-02 | C1C1111F5N1830 | 0.75d | 0d |  | Helper [343.2 h]; Carpenter [686.4 h] | 72.38 | Civil | 12 | 1 | MB |
| C1C1111F5N1920 |  | B02- AREA-1 Rebar fixing |  | 6.25d | 2019-05-04 | 2019-05-08 | C1C1111F5N1910, B640 FS+32.5d | 0.75d | 0d |  | Helper [343.2 h]; Steel Fixer [715 h] | 74.39 | Civil | 12 | 1 | MB |
| C1C1111F5N1930 |  | B02- AREA-1 Concrete Casting Slab (41.02cm) |  | 2.5d | 2019-05-09 | 2019-05-11 | C1C1111F5N1920 | 0.75d | 0d |  | Concrete Casting [44.15 CUM]; Helper [143 h]; Mason [572 h] | 50.26 | Civil | 12 | 1 | MB |
| C1C1111F5N1940 |  | B02- AREA-1 Waterproofing wall (not by ZSCC) |  | 6.25d | 2019-05-12 | 2019-05-16 | C1C1111F5N1930 | 0.75d | 0d |  |  |  | Civil | 12 | 1 | MB |
| C1C1111F5N1950 |  | B02- AREA-1 Rebar fixing wall / column / staircase |  | 6.25d | 2019-05-18 | 2019-05-22 | C1C1111F5N1930, C1C1111F5N1940 | 0.75d | 0d |  | Helper [457.6 h]; Steel Fixer [750 h] | 84.9 | Civil | 12 | 1 | MB |
| C1C1111F5N1960 |  | B02- AREA-1 Formwork fixing wall / column / staircase |  | 6.25d | 2019-05-22 | 2019-05-27 | C1C1111F5N1950 SS+5d | 0.75d | 0d |  | Helper [457.6 h]; Carpenter [750 h] | 84.9 | Civil | 12 | 1 | MB |
| C1C1111F5N1970 |  | B02- AREA-1 Concrete Casting wall / column / staircase |  | 2.5d | 2019-05-28 | 2019-05-29 | C1C1111F5N1960, LOE-SUM1-200 FF | 0.75d | 0d |  | Concrete Casting [328.41 CUM]; Helper [143 h]; Mason [429 h] | 40.21 | Civil | 12 | 1 | MB |
|  | 10 | **Top Slab Level B01 North ( AREA-2 & AREA-1 )** |  |  | 2019-05-06 | 2019-06-17 |  |  |  |  |  |  |  |  |  |  |
| LOE-SUM1-210 |  | North . B01 - Concrete Works | level of effort | 46.25d | 2019-05-06 | 2019-06-17 | C1C1111F5N1980 SS | 0.75d | 0d | Saudi |  |  | Civil |  |  |  |
|  | 1 | **Top Slab Level ( B01 . AREA-2)** |  |  | 2019-05-06 | 2019-05-21 |  |  |  |  |  |  |  |  |  |  |
| C1C1111F5N1980 |  | B01- AREA-2 Formwork and Slab fixing |  | 7.5d | 2019-05-06 | 2019-05-12 | C1C1111F5N1900 | 0.75d | 0d |  | Helper [343.2 h]; Carpenter [686.4 h] | 72.38 | Civil | 12 | 2 | MB |
| C1C1111F5N1990 |  | B01- AREA-2 Rebar fixing |  | 7.5d | 2019-05-13 | 2019-05-19 | C1C1111F5N1980, B680 FS+32.5d, C1C1111F5N1980 SS+5d | 0.75d | 0d |  | Helper [343.2 h]; Steel Fixer [715 h] | 74.39 | Civil | 12 | 2 | MB |
| C1C1111F5N2000 |  | B01- AREA-2 Concrete Casting Slab (999cm) |  | 2.5d | 2019-05-20 | 2019-05-21 | C1C1111F5N1990, C1C1111F5N1980 SS | 0.75d | 0d |  | Concrete Casting [1075.34 CUM]; Helper [143 h]; Mason [572 h] | 50.26 | Civil | 12 | 2 | MB |
|  | 2 | **Top Slab Level ( B01 . AREA-1)** |  |  | 2019-05-30 | 2019-06-17 |  |  |  |  |  |  |  |  |  |  |
| C1C1111F5N2010 |  | B01- AREA-1 Formwork and Slab fixing |  | 7.5d | 2019-05-30 | 2019-06-09 | C1C1111F5N1970 | 0.75d | 0d |  | Helper [343.2 h]; Carpenter [686.4 h] | 72.38 | Civil | 12 | 1 | MB |
| C1C1111F5N2020 |  | B01- AREA-1 Rebar fixing |  | 7.5d | 2019-06-09 | 2019-06-15 | C1C1111F5N2010 FF+6.25d, C1C1111F5N2010 SS+5d, B690 FS+32.5d | 0.75d | 0d |  | Helper [343.2 h]; Steel Fixer [715 h] | 74.39 | Civil | 12 | 1 | MB |
| C1C1111F5N2030 |  | B01- AREA-1 Concrete Casting Slab (861cm) |  | 2.5d | 2019-06-16 | 2019-06-17 | C1C1111F5N2020, LOE-SUM1-210 FF | 0.75d | 0d |  | Concrete Casting [926.79 CUM]; Helper [143 h]; Mason [572 h] | 50.26 | Civil | 12 | 1 | MB |

| ID | WBS | Activity | Type | Duration | Start | Finish | Predecessors | Total float | Free float | Constraint | Calendar | Resources | Cost | Discipline | AREA | LOCATION |
| --- | --- | --- | --- | --- | --- | --- | --- | --- | --- | --- | --- | --- | --- | --- | --- | --- |
|  | 11 | **Paraphet Wall above Top Slab North ( AREA-2 & AREA-1 )** |  |  | 2019-05-22 | 2019-07-21 |  |  |  |  |  |  |  |  |  |  |
| LOE-SUM1-220 |  | North . B01 - Concrete Works | level of effort | 65d | 2019-05-22 | 2019-07-21 | C1C1111F5N2050 SS | 14.5d | 0d |  | Saudi |  |  | Civil |  |  |
|  | 1 | **Paraphet Wall above Top Slab ( B01 . AREA-2)** |  |  | 2019-05-22 | 2019-06-27 |  |  |  |  |  |  |  |  |  |  |
| C1C1111F5N2050 |  | B01- AREA-2 Rebar fixing column / wall / staircase |  | 7.5d | 2019-05-22 | 2019-05-28 | C1C1111F5N2000 | 0.75d | 0d |  |  | Helper [400.4 h]; Steel Fixer [858 h] | 88.47 | Civil | 2 | MB |
| C1C1111F5N2060 |  | B01- AREA-2 Formwork fixing column / wall/ staircase |  | 7.5d | 2019-05-29 | 2019-06-08 | C1C1111F5N2050 | 0.75d | 0d |  |  | Helper [343.2 h]; Carpenter [858 h] | 84.45 | Civil | 2 | MB |
| C1C1111F5N2070 |  | B01- AREA-2 Concrete Casting column / wall / staircase |  | 2.5d | 2019-06-09 | 2019-06-10 | C1C1111F5N2060, C1C1111F5N2220 | 0.75d | 0d |  |  | Concrete Casting [173.84 CUM]; Helper [143 h]; Mason [429 h] | 40.21 | Civil | 2 | MB |
| C1C1111F5N2082 |  | B01- AREA-2 Waterproofing wall (not by ZSCC) |  | 7.5d | 2019-06-11 | 2019-06-17 | C1C1111F5N2000, C1C1111F5N2070 | 32d | 0d |  |  |  |  | Civil | 2 | MB |
| C1C1111F5N2084 |  | B01- AREA-2 Protection Screed |  | 3.75d | 2019-06-18 | 2019-06-20 | C1C1111F5N2082 | 32d | 0d |  |  | Mason [257.4 h]; Helper [128.7 h] | 27.15 | Civil | 2 | MB |
| C1C1111F5N2086 |  | B01- AREA-2 Backfilling & compaction (Optional) |  | 7.5d | 2019-06-22 | 2019-06-27 | C1C1111F5N2084 SS, C1C1111F5N2084 FF, C1C1111F5C1980, C1C1111F5N2084 | 32d | 17.5d |  |  | Helper [514.8 h] | 36.19 | Civil | 2 | MB |
|  | 2 | **Paraphet Wall above Top Slab ( B01 . AREA-1)** |  |  | 2019-06-18 | 2019-07-21 |  |  |  |  |  |  |  |  |  |  |
| C1C1111F5N2090 |  | B01- AREA-1 Rebar fixing column / wall / staircase |  | 7.5d | 2019-06-18 | 2019-06-24 | C1C1111F5N2030, C1C1111F5N2230 FF | 14.5d | 0d |  |  | Helper [400.4 h]; Steel Fixer [858 h] | 88.47 | Civil | 1 | MB |
| C1C1111F5N2100 |  | B01- AREA-1 Formwork fixing column / wall/ staircase |  | 7.5d | 2019-06-25 | 2019-07-01 | C1C1111F5N2090, C1C1111F5N2240 FF | 14.5d | 0d |  |  | Helper [343.2 h]; Carpenter [858 h] | 84.45 | Civil | 1 | MB |
| C1C1111F5N2110 |  | B01- AREA-1 Concrete Casting column / wall / staircase |  | 2.5d | 2019-07-02 | 2019-07-03 | C1C1111F5N2220 FF, C1C1111F5N2100 | 14.5d | 0d |  |  | Concrete Casting [78.32 CUM]; Helper [143 h]; Mason [429 h] | 40.21 | Civil | 1 | MB |
| C1C1111F5N2120 |  | B01- AREA-1 Waterproofing wall (not by ZSCC) |  | 7.5d | 2019-07-04 | 2019-07-10 | C1C1111F5N2030, C1C1111F5N2110 | 14.5d | 0d |  |  |  |  | Civil | 1 | MB |
| C1C1111F5N2130 |  | B01- AREA-1 Protection Screed |  | 3.75d | 2019-07-11 | 2019-07-14 | C1C1111F5N2120 | 14.5d | 0d |  |  | Mason [257.4 h]; Helper [128.7 h] | 27.15 | Civil | 1 | MB |
| C1C1111F5N2140 |  | B01- AREA-1 Backfilling & compaction (Optional) |  | 7.5d | 2019-07-15 | 2019-07-21 | C1C1111F5N2130, C1C1111F5N2086, LOE-SUM1-220 FF | 14.5d | 15d |  |  | Helper [514.8 h] | 36.19 | Civil | 1 | MB |
|  | 1 | **LOE Commodities North ( B01 to B07)** |  |  | 2018-10-13 | 2019-07-03 |  |  |  |  |  |  |  |  |  |  |
| C1C1111F5N2230 |  | LOE - North B07 to B01 - Rebar | level of effort | 270d | 2018-10-13 | 2019-06-24 | C1C1111F5N320 SS | 14.5d | 0d |  |  | Steel Reinforcement [3037.41 tons] |  | Civil |  | MB |
| C1C1111F5N2240 |  | LOE - North B07 to B01 - Formworks | level of effort | 266.25d | 2018-10-23 | 2019-07-01 | C1C1111F5N330 SS | 14.5d | 0d |  |  | Formworks [31426.3 Square Meter] |  | Civil |  | MB |
| C1C1111F5N2220 |  | LOE - LOE - Mass concrete infill between pemanent wall and SOE | level of effort | 262.5d | 2018-10-29 | 2019-07-03 | C1C1111F5N340 SS | 14.5d | 0d |  |  | Concrete infill [1764 CUM] |  | Civil |  | MB |
|  | 6 | **DISMANTLE STEEL STRUCTURE Under Traffic Deck** |  |  | 2019-07-04 | 2020-01-16 |  |  |  |  |  |  |  |  |  |  |
| C1C1111F5N3010 |  | Relocation of existing utility lines along the traffic deck |  | 22.5d | 2019-07-04 | 2019-07-24 | C1C1111F5N2110 | 153.5d | 0d |  |  | Skilled Labour [85.8 h]; Unskilled Labour [57.2 h] | 10.9 | Arch'l |  | MB |
| C1C1111F5N3020 |  | Erecting the top Header Beam Holder on Top Slab |  | 32.5d | 2019-07-25 | 2019-08-27 | C1C1111F5N2110, C1C1111F5N3010 | 153.5d | 0d |  |  | Skilled Labour [85.8 h]; Unskilled Labour [57.2 h] | 10.9 | Arch'l |  | MB |
| C1C1111F5N3030 |  | Statge 1 - Dismantling of steel structure under traffic deck |  | 32.5d | 2019-08-28 | 2019-09-29 | C1C1111F5N3020 | 153.5d | 0d |  |  | Skilled Labour [85.8 h]; Unskilled Labour [57.2 h] | 10.9 | Arch'l |  | MB |
| C1C1111F5N3040 |  | Dismantling the top Header Beam Holder on Top Slab |  | 32.5d | 2019-09-09 | 2019-10-10 | C1C1111F5N3030 FF+12.5d | 153.5d | 154d |  |  | Skilled Labour [85.8 h]; Unskilled Labour [57.2 h] | 10.9 | Arch'l |  | MB |
| C1C1111F5N3050 |  | Stage 2 of Traffic deck - UD relocation |  | 32.5d | 2019-12-18 | 2020-01-16 | C1C1111F5N2110 | 3.75d | 0d | start on or after 2019-12-18 |  |  |  | Civil |  | MB |

| ID | WBS | Activity | Type | Duration | Start | Finish | Predecessors | Total float | Free float | Constraint | Calendar | Resources | Cost | Discipline | LOCATION |
| --- | --- | --- | --- | --- | --- | --- | --- | --- | --- | --- | --- | --- | --- | --- | --- |
|  | 4 | **ENTRANCES** |  |  | 2018-11-12 | 2019-04-30 |  |  |  |  |  |  |  |  |  |
|  | 1 | **NORTH WEST Entrance (NEE)** |  |  | 2018-11-12 | 2019-02-27 |  |  |  |  |  |  |  |  |  |
| LOE-SUM1-230 |  | NEE . B01 - Concrete Works | level of effort | 116.25d | 2018-11-12 | 2019-02-27 | C1C1111F5NEE-010 SS | 98.5d | 0d |  | Saudi |  |  | Civil |  |
|  | 2 | **Elev Pit at Tech'l Level B04 . (NEE)** |  |  | 2018-11-12 | 2018-11-29 |  |  |  |  |  |  |  |  |  |
| C1C1111F5NEE-010 |  | Elev Pit slab B04 . NEE Waterproofing (not by ZSCC), Blinding |  | 2.5d | 2018-11-12 | 2018-11-13 | C1C1111F5N480 | -18.75d | 0d | start on or after 2018-11-11 |  |  |  | Civil | NEE |
| C1C1111F5NEE-020 |  | Elev Pit slab B04 . NEE Rebar fixing |  | 2.5d | 2018-11-14 | 2018-11-15 | B700, C1C1111F5NEE-010 | -18.75d | 0d |  |  | Helper [143 h]; Steel Fixer [343.2 h] | 34.18 | Civil | NEE |
| C1C1111F5NEE-030 |  | Elev Pit slab B04 . NEE Formwork fixing |  | 2.5d | 2018-11-17 | 2018-11-18 | C1C1111F5NEE-020 | -18.75d | 0d |  |  | Helper [214.5 h]; Carpenter [343.2 h] | 39.21 | Civil | NEE |
| C1C1111F5NEE-040 |  | Elev Pit slab B04 . NEE Concrete Casting base slab (25cm) |  | 2.5d | 2018-11-19 | 2018-11-20 | C1C1111F5NEE-030 | -18.75d | 0d |  |  | Concrete Casting [87.51 CUM]; Helper [143 h]; Mason [429 h] | 40.21 | Civil | NEE |
|  | 2 | **Elev Wall Tech'l Level ( B03 . NEE)** |  |  | 2018-11-21 | 2018-11-29 |  |  |  |  |  |  |  |  |  |
| C1C1111F5NEE-050 |  | B03. NEE Waterproofing Elev Wall (not by ZSCC) |  | 2.5d | 2018-11-21 | 2018-11-22 | C1C1111F5NEE-040 | -18.75d | 0d |  |  |  |  | Civil | NEE |
| C1C1111F5NEE-060 |  | B04 . NEE Rebar fixing Elev wall / column / staircase |  | 2.5d | 2018-11-24 | 2018-11-25 | C1C1111F5NEE-050 | -18.75d | 0d |  |  | Helper [171.6 h]; Steel Fixer [343.2 h] | 36.19 | Civil | NEE |
| C1C1111F5NEE-070 |  | B03. NEE Formwork fixing Elev wall / column |  | 2.5d | 2018-11-26 | 2018-11-27 | C1C1111F5NEE-060 | -18.75d | 0d |  |  | Helper [214.5 h]; Carpenter [343.2 h] | 39.21 | Civil | NEE |
| C1C1111F5NEE-080 |  | B03. NEE Concrete Casting & Striking wall (7.2cm) |  | 2.5d | 2018-11-28 | 2018-11-29 | C1C1111F5NEE-070 | -18.75d | 0d |  |  | Concrete Casting [28.18 CUM]; Helper [143 h]; Mason [429 h] | 40.21 | Civil | NEE |
|  | 1 | **Base Slab at Concourse Level B03 . NEE** |  |  | 2018-12-01 | 2018-12-27 |  |  |  |  |  |  |  |  |  |
| C1C1111F5NEE-090 |  | Base slab B03 . NEE Waterproofing (not by ZSCC), Blinding |  | 3.75d | 2018-12-01 | 2018-12-03 | C1C1111F5NEE-080 | -18.75d | 0d |  |  |  |  | Civil | NEE |
| C1C1111F5NEE-100 |  | Base slab B03 . NEE Rebar fixing |  | 3.75d | 2018-12-04 | 2018-12-06 | C1C1111F5NEE-090, B710 | -18.75d | 0d |  |  | Helper [386.1 h]; Steel Fixer [514.8 h] | 63.33 | Civil | NEE |
| C1C1111F5NEE-110 |  | Base slab B03 . NEE Formwork fixing |  | 3.75d | 2018-12-08 | 2018-12-10 | C1C1111F5NEE-100 | -18.75d | 0d |  |  | Helper [214.5 h]; Carpenter [429 h] | 45.24 | Civil | NEE |
| C1C1111F5NEE-120 |  | Base slab B03 . NEE Concrete Casting base slab (96cm) |  | 2.5d | 2018-12-11 | 2018-12-12 | C1C1111F5NEE-110 | -18.75d | 0d |  |  | Concrete Casting [336.01 CUM]; Helper [143 h]; Mason [514.8 h] | 46.24 | Civil | NEE |
|  | 2 | **Outer & Inner Wall Concourse Level ( B03 . NEE )** |  |  | 2018-12-13 | 2018-12-27 |  |  |  |  |  |  |  |  |  |
| C1C1111F5NEE-130 |  | B03. NEE Waterproofing Wall (not by ZSCC) |  | 3.75d | 2018-12-13 | 2018-12-16 | C1C1111F5NEE-120 | -18.75d | 0d |  |  |  |  | Civil | NEE |
| C1C1111F5NEE-140 |  | B03. NEE Rebar fixing wall / column / staircase |  | 5d | 2018-12-17 | 2018-12-20 | C1C1111F5NEE-130 | -18.75d | 0d |  |  | Helper [286 h]; Steel Fixer [572 h] | 60.32 | Civil | NEE |
| C1C1111F5NEE-150 |  | B03. NEE Formwork fixing wall / column / staircase |  | 5d | 2018-12-22 | 2018-12-25 | C1C1111F5NEE-140 | -18.75d | 0d |  |  | Helper [214.5 h]; Carpenter [715 h] | 65.34 | Civil | NEE |
| C1C1111F5NEE-160 |  | B03. NEE Concrete Casting & Striking wall |  | 2.5d | 2018-12-26 | 2018-12-27 | C1C1111F5NEE-150 | -18.75d | 0d |  |  | Concrete Casting [700.02 CUM]; Helper [143 h]; Mason [429 h] | 40.21 | Civil | NEE |
|  | 3 | **TV Louver Level B02 . NEE** |  |  | 2018-12-29 | 2019-01-20 |  |  |  |  |  |  |  |  |  |
|  | 1 | **TV Louver Level ( B02 . NEE )** |  |  | 2018-12-29 | 2019-01-20 |  |  |  |  |  |  |  |  |  |
| C1C1111F5NEE-170 |  | B02. NEE Formwork and Slab fixing |  | 3.75d | 2018-12-29 | 2018-12-31 | C1C1111F5NEE-160 | -18.75d | 0d |  |  | Helper [343.2 h]; Carpenter [514.8 h] | 60.32 | Civil | NEE |
| C1C1111F5NEE-180 |  | B02. NEE Rebar fixing |  | 3.75d | 2019-01-01 | 2019-01-03 | C1C1111F5NEE-170, B720 FS+22.5d | -18.75d | 0d |  |  | Helper [343.2 h]; Steel Fixer [715 h] | 74.39 | Civil | NEE |
| C1C1111F5NEE-190 |  | B02. NEE Concrete Casting Slab |  | 2.5d | 2019-01-05 | 2019-01-06 | C1C1111F5NEE-180 | -18.75d | 0d |  |  | Concrete Casting [658.02 CUM]; Helper [143 h]; Mason [514.8 h] | 46.24 | Civil | NEE |
| C1C1111F5NEE-200 |  | B02. NEE Waterproofing wall (not by ZSCC) |  | 3.75d | 2019-01-07 | 2019-01-09 | C1C1111F5NEE-190 | -18.75d | 0d |  |  |  |  | Civil | NEE |
| C1C1111F5NEE-210 |  | B02. NEE Rebar fixing wall / column / staircase |  | 3.75d | 2019-01-10 | 2019-01-13 | C1C1111F5NEE-200 | -18.75d | 0d |  |  | Helper [360 h]; Steel Fixer [540 h] | 63.27 | Civil | NEE |
| C1C1111F5NEE-220 |  | B02. NEE Formwork fixing wall / column / staircase |  | 3.75d | 2019-01-15 | 2019-01-17 | C1C1111F5NEE-210 SS+5d | -18.75d | 0d |  |  | Helper [457.6 h]; Carpenter [514.8 h] | 68.36 | Civil | NEE |
| C1C1111F5NEE-230 |  | B02. NEE Concrete Casting wall / column / staircase |  | 2.5d | 2019-01-19 | 2019-01-20 | C1C1111F5NEE-220 | -18.75d | 0d |  |  | Concrete Casting [315.01 CUM]; Helper [143 h]; Mason [429 h] | 40.21 | Civil | NEE |

| ID | WBS | Activity | Type | Duration | Start | Finish | Predecessors | Total float | Free float | Constraint | Calendar | Resources | Cost | Discipline | LOCATION |
| --- | --- | --- | --- | --- | --- | --- | --- | --- | --- | --- | --- | --- | --- | --- | --- |
|  | 4 | **Top Slab Level B01 . NEE** |  |  | 2019-01-21 | 2019-01-31 |  |  |  |  |  |  |  |  |  |
|  | 1 | **Top Slab Level ( B01 . NEE )** |  |  | 2019-01-21 | 2019-01-31 |  |  |  |  |  |  |  |  |  |
| C1C1111F5NEE-240 |  | B01. NEE Formwork and Slab fixing |  | 5d | 2019-01-21 | 2019-01-24 | C1C1111F5NEE-230 | -18.75d | 0d |  |  | Helper [343.2 h]; Carpenter [686.4 h] | 72.38 | Civil | NEE |
| C1C1111F5NEE-250 |  | B01. NEE Rebar fixing |  | 5d | 2019-01-26 | 2019-01-29 | B730 FS+32.5d, C1C1111F5NEE-240 | -18.75d | 0d |  |  | Helper [343.2 h]; Steel Fixer [715 h] | 74.39 | Civil | NEE |
| C1C1111F5NEE-260 |  | B01. NEE Concrete Casting Slab (30cm) |  | 2.5d | 2019-01-30 | 2019-01-31 | C1C1111F5NEE-250 | -18.75d | 0d |  |  | Concrete Casting [55 CUM]; Helper [143 h]; Mason [514.8 h] | 46.24 | Civil | NEE |
|  | 5 | **Paraphet Wall above Top Slab B01 . NEE** |  |  | 2019-02-02 | 2019-02-27 |  |  |  |  |  |  |  |  |  |
|  | 1 | **Paraphet Wall above Top Slab ( B01 . NEE)** |  |  | 2019-02-02 | 2019-02-27 |  |  |  |  |  |  |  |  |  |
| C1C1111F5NEE-280 |  | B01. NEE Rebar fixing column / wall / staircase |  | 5d | 2019-02-02 | 2019-02-05 | C1C1111F5NEE-260, B740 FS+32.5d, C1C1111F5NEE3400 FF | 98.5d | 0d |  |  | Helper [400.4 h]; Steel Fixer [858 h] | 88.47 | Civil | NEE |
| C1C1111F5NEE-290 |  | B01. NEE Formwork fixing column / wall/ staircase |  | 5d | 2019-02-06 | 2019-02-10 | C1C1111F5NEE3410 FF, C1C1111F5NEE-280 | 98.5d | 0d |  |  | Helper [343.2 h]; Carpenter [686.4 h] | 72.38 | Civil | NEE |
| C1C1111F5NEE-300 |  | B01. NEE Concrete Casting column / wall / staircase (15cm) |  | 2.5d | 2019-02-11 | 2019-02-12 | C1C1111F5NEE-290, C1C1111F5NEE3390 FF | 98.5d | 0d |  |  | Concrete Casting [103 CUM]; Helper [143 h]; Mason [429 h] | 40.21 | Civil | NEE |
| C1C1111F5NEE-310 |  | B01. NEE Waterproofing wall (not by ZSCC) |  | 5d | 2019-02-13 | 2019-02-17 | C1C1111F5NEE-300 | 98.5d | 0d |  |  |  |  | Civil | NEE |
| C1C1111F5NEE-320 |  | B01. NEE Protection Screed |  | 3.75d | 2019-02-18 | 2019-02-20 | C1C1111F5NEE-310 | 98.5d | 0d |  |  | Mason [257.4 h]; Helper [128.7 h] | 27.15 | Civil | NEE |
| C1C1111F5NEE-3330 |  | B01. NEE Backfilling & compaction (Optional) |  | 7.5d | 2019-02-21 | 2019-02-27 | C1C1111F5NEE-320, LOE-SUM1-230 FF | 98.5d | 1.25d |  |  | Helper [514.8 h] | 36.19 | Civil | NEE |
|  | 11 | **LOE Commodities NEE ( B01 to B04)** |  |  | 2018-11-14 | 2019-02-12 |  |  |  |  |  |  |  |  |  |
| C1C1111F5NEE3400 |  | LOE - NEE B04 to B01 - Rebar | level of effort | 90d | 2018-11-14 | 2019-02-05 | C1C1111F5NEE-020 SS | 98.5d | 0d |  |  | Steel Reinforcement [445.86 tons] |  | Civil | NEE |
| C1C1111F5NEE3410 |  | LOE - NEE B04 to B01 - Formworks | level of effort | 92.5d | 2018-11-17 | 2019-02-10 | C1C1111F5NEE-030 SS | 98.5d | 0d |  |  | Formworks [4613 Square Meter] |  | Civil | NEE |
| C1C1111F5NEE3390 |  | LOE - NEE B04 to B01 - LOE - Mass concrete infill | level of effort | 92.5d | 2018-11-19 | 2019-02-12 | C1C1111F5NEE-040 SS | 98.5d | 0d |  |  | Concrete infill [300 CUM] |  | Civil | NEE |
|  | 3 | **NORTH WEST Entrance (NWE)** |  |  | 2018-12-10 | 2019-04-30 |  |  |  |  |  |  |  |  |  |
| LOE-SUM1-240 |  | NWE . Concrete Works | level of effort | 152.5d | 2018-12-10 | 2019-04-30 | C1C1111F5NWE-010 SS | 127.25d | 0d |  | Saudi |  |  | Civil |  |
|  | 2 | **Base Slab at Tech'l Level B04 . (NWE) + Elev Pit** |  |  | 2018-12-10 | 2019-01-10 |  |  |  |  |  |  |  |  |  |
| C1C1111F5NWE-010 |  | Base slab B04 . NWE Waterproofing (not by ZSCC), Blinding |  | 3.75d | 2018-12-10 | 2018-12-12 | C1C1111F5NEE-050 | 3.75d | 0d | start on or after 2018-12-09 |  |  |  | Civil | NWE |
| C1C1111F5NWE-020 |  | Base slab B04 . NWE Rebar fixing |  | 3.75d | 2018-12-13 | 2018-12-16 | C1C1111F5NWE-010 | 3.75d | 0d |  |  | Helper [214.5 h]; Steel Fixer [343.2 h] | 39.21 | Civil | NWE |
| C1C1111F5NWE-030 |  | Base slab B04 . NWE Formwork fixing |  | 3.75d | 2018-12-17 | 2018-12-19 | C1C1111F5NWE-020 | 3.75d | 0d |  |  | Helper [214.5 h]; Carpenter [429 h] | 45.24 | Civil | NWE |
| C1C1111F5NWE-040 |  | Base slab B04 . NWE Concrete Casting base slab |  | 2.5d | 2018-12-24 | 2018-12-25 | C1C1111F5NWE-030 FS+3.75d | 3.75d | 0d |  |  | Concrete Casting [406.34 CUM]; Helper [143 h]; Mason [429 h] | 40.21 | Civil | NWE |

| ID | WBS | Activity | Duration | Start | Finish | Predecessors | Total float | Free float | Resources | Cost | Discipline | LOCATION |
| --- | --- | --- | --- | --- | --- | --- | --- | --- | --- | --- | --- | --- |
|  | 2 | **Outer & Inner Wall Tech'l Level ( B03 . NWE)** |  | 2018-12-26 | 2019-01-10 |  |  |  |  |  |  |  |
| C1C1111F5NWE-050 |  | B03. NWE Waterproofing Wall (not by ZSCC) | 5d | 2018-12-26 | 2018-12-30 | C1C1111F5NWE-040 | 3.75d | 0d |  |  | Civil | NWE |
| C1C1111F5NWE-060 |  | B04 . NWE Rebar fixing wall / column | 5d | 2018-12-31 | 2019-01-03 | C1C1111F5NWE-050 | 3.75d | 0d | Helper [171.6 h]; Steel Fixer [429 h] | 42.22 | Civil | NWE |
| C1C1111F5NWE-070 |  | B03. NWE Formwork fixing wall / column | 5d | 2019-01-05 | 2019-01-08 | C1C1111F5NWE-060 | 3.75d | 0d | Helper [214.5 h]; Carpenter [715 h] | 65.34 | Civil | NWE |
| C1C1111F5NWE-080 |  | B03. NWE Concrete Casting & Striking wall | 2.5d | 2019-01-09 | 2019-01-10 | C1C1111F5NWE-070 | 3.75d | 0d | Concrete Casting [373.6 CUM]; Helper [143 h]; Mason [429 h] | 40.21 | Civil | NWE |
|  | 1 | **Base Slab at Concourse Level B03 . NWE** |  | 2019-01-12 | 2019-02-14 |  |  |  |  |  |  |  |
| C1C1111F5NWE-090 |  | Base slab B03 . NWE Waterproofing (not by ZSCC), Blinding | 5d | 2019-01-12 | 2019-01-15 | C1C1111F5NWE-080 | 3.75d | 0d |  |  | Civil | NWE |
| C1C1111F5NWE-100 |  | Base slab B03 . NWE Rebar fixing | 5d | 2019-01-16 | 2019-01-20 | C1C1111F5NWE-090 | 3.75d | 0d | Helper [386.1 h]; Steel Fixer [686.4 h] | 75.39 | Civil | NWE |
| C1C1111F5NWE-110 |  | Base slab B03 . NWE Formwork fixing | 5d | 2019-01-21 | 2019-01-24 | C1C1111F5NWE-100 | 3.75d | 0d | Helper [214.5 h]; Carpenter [457.6 h] | 47.25 | Civil | NWE |
| C1C1111F5NWE-120 |  | Base slab B03 . NWE Concrete Casting base slab | 2.5d | 2019-01-26 | 2019-01-27 | C1C1111F5NWE-110 | 3.75d | 0d | Concrete Casting [500 CUM]; Helper [143 h]; Mason [429 h] | 40.21 | Civil | NWE |
|  | 2 | **Outer & Inner Wall Concourse Level ( B03 . NWE )** |  | 2019-01-28 | 2019-02-14 |  |  |  |  |  |  |  |
| C1C1111F5NWE-130 |  | B03. NWE Waterproofing Wall (not by ZSCC) | 5d | 2019-01-28 | 2019-01-31 | C1C1111F5NWE-120 | 3.75d | 0d |  |  | Civil | NWE |
| C1C1111F5NWE-140 |  | B03. NWE Rebar fixing wall / column / staircase | 6.25d | 2019-02-02 | 2019-02-06 | C1C1111F5NWE-130 | 3.75d | 0d | Helper [171.6 h]; Steel Fixer [686.4 h] | 60.31 | Civil | NWE |
| C1C1111F5NWE-150 |  | B03. NWE Formwork fixing wall / column / staircase | 6.25d | 2019-02-07 | 2019-02-12 | C1C1111F5NWE-140 | 3.75d | 0d | Helper [214.5 h]; Carpenter [715 h] | 65.34 | Civil | NWE |
| C1C1111F5NWE-160 |  | B03. NWE Concrete Casting & Striking wall | 2.5d | 2019-02-13 | 2019-02-14 | C1C1111F5NWE-150 | 3.75d | 0d | Concrete Casting [480 CUM]; Helper [143 h]; Mason [429 h] | 40.21 | Civil | NWE |
|  | 3 | **TV Louver Level B02 . NWE** |  | 2019-02-16 | 2019-03-16 |  |  |  |  |  |  |  |
|  | 1 | **TV Louver Level ( B02 . NWE )** |  | 2019-02-16 | 2019-03-16 |  |  |  |  |  |  |  |
| C1C1111F5NWE-170 |  | B02. NWE Formwork and Slab fixing | 5d | 2019-02-16 | 2019-02-19 | C1C1111F5NWE-160 | 3.75d | 0d | Helper [343.2 h]; Carpenter [686.4 h] | 72.38 | Civil | NWE |
| C1C1111F5NWE-180 |  | B02. NWE Rebar fixing | 5d | 2019-02-20 | 2019-02-24 | C1C1111F5NWE-170 | 3.75d | 0d | Helper [343.2 h]; Steel Fixer [715 h] | 74.39 | Civil | NWE |
| C1C1111F5NWE-190 |  | B02. NWE Concrete Casting Slab | 2.5d | 2019-02-25 | 2019-02-26 | C1C1111F5NWE-180 | 3.75d | 0d | Concrete Casting [139 CUM]; Helper [143 h]; Mason [514.8 h] | 46.24 | Civil | NWE |
| C1C1111F5NWE-200 |  | B02. NWE Waterproofing wall (not by ZSCC) | 5d | 2019-02-27 | 2019-03-03 | C1C1111F5NWE-190 | 3.75d | 0d |  |  | Civil | NWE |
| C1C1111F5NWE-210 |  | B02. NWE Rebar fixing wall / column / staircase | 6.25d | 2019-03-04 | 2019-03-09 | C1C1111F5NWE-200 | 3.75d | 0d | Helper [286 h]; Steel Fixer [572 h] | 60.32 | Civil | NWE |
| C1C1111F5NWE-220 |  | B02. NWE Formwork fixing wall / column / staircase | 6.25d | 2019-03-09 | 2019-03-13 | C1C1111F5NWE-210 SS+5d | 3.75d | 0d | Helper [286 h]; Carpenter [572 h] | 60.32 | Civil | NWE |
| C1C1111F5NWE-230 |  | B02. NWE Concrete Casting wall / column / staircase | 2.5d | 2019-03-14 | 2019-03-16 | C1C1111F5NWE-220 | 3.75d | 0d | Concrete Casting [439.85 CUM]; Helper [143 h]; Mason [429 h] | 40.21 | Civil | NWE |

| ID | WBS | Activity | Type | Duration | Start | Finish | Predecessors | Total float | Free float | Constraint | Calendar | Resources | Cost | Discipline | LOCATION |
| --- | --- | --- | --- | --- | --- | --- | --- | --- | --- | --- | --- | --- | --- | --- | --- |
|  | 4 | **Top Slab Level B01 . NWE** |  |  | 2019-03-17 | 2019-04-01 |  |  |  |  |  |  |  |  |  |
|  | 1 | **Top Slab Level ( B01 . NWE )** |  |  | 2019-03-17 | 2019-04-01 |  |  |  |  |  |  |  |  |  |
| C1C1111F5NWE-240 |  | B01. NWE Formwork and Slab fixing |  | 7.5d | 2019-03-17 | 2019-03-23 | C1C1111F5NWE-230 | 3.75d | 0d |  |  | Helper [343.2 h]; Carpenter [686.4 h] | 72.38 | Civil | NWE |
| C1C1111F5NWE-250 |  | B01. NWE Rebar fixing |  | 7.5d | 2019-03-24 | 2019-03-30 | C1C1111F5NWE-240 | 3.75d | 0d |  |  | Helper [343.2 h]; Steel Fixer [715 h] | 74.39 | Civil | NWE |
| C1C1111F5NWE-260 |  | B01. NWE Concrete Casting Slab |  | 2.5d | 2019-03-31 | 2019-04-01 | C1C1111F5NWE-250 | 3.75d | 0d |  |  | Concrete Casting [121.42 CUM]; Helper [143 h]; Mason [514.8 h] | 46.24 | Civil | NWE |
|  | 5 | **Paraphet Wall above Top Slab B01 . NWE** |  |  | 2019-04-02 | 2019-04-30 |  |  |  |  |  |  |  |  |  |
|  | 1 | **Paraphet Wall above Top Slab ( B01 . NWE)** |  |  | 2019-04-02 | 2019-04-30 |  |  |  |  |  |  |  |  |  |
| C1C1111F5NWE-280 |  | B01. NWE Rebar fixing column / wall / staircase |  | 6.25d | 2019-04-02 | 2019-04-07 | C1C1111F5NWE-260, C1C1111F5NWE-350 FF | 119.75d | 0d |  |  | Helper [357.5 h]; Steel Fixer [572 h] | 65.34 | Civil | NWE |
| C1C1111F5NWE-290 |  | B01. NWE Formwork fixing column / wall/ staircase |  | 6.25d | 2019-04-08 | 2019-04-13 | C1C1111F5NWE-280, C1C1111F5NWE-360 FF | 119.75d | 0d |  |  | Helper [343.2 h]; Carpenter [572 h] | 64.34 | Civil | NWE |
| C1C1111F5NWE-300 |  | B01. NWE Concrete Casting column / wall / staircase |  | 2.5d | 2019-04-14 | 2019-04-15 | C1C1111F5NWE-290, C1C1111F5NWE-340 FF | 119.75d | 0d |  |  | Concrete Casting [321.63 CUM]; Helper [143 h]; Mason [429 h] | 40.21 | Civil | NWE |
| C1C1111F5NWE-310 |  | B01. NWE Waterproofing wall (not by ZSCC) |  | 5d | 2019-04-16 | 2019-04-20 | C1C1111F5NWE-300 | 119.75d | 0d |  |  |  |  | BACS | NWE |
| C1C1111F5NWE-320 |  | B01. NWE Protection Screed |  | 3.75d | 2019-04-21 | 2019-04-23 | C1C1111F5NWE-310 | 119.75d | 0d |  |  | Mason [257.4 h]; Helper [128.7 h] | 27.15 | Civil | NWE |
| C1C1111F5NWE-330 |  | B01. NWE Backfilling & compaction (Optional) |  | 7.5d | 2019-04-24 | 2019-04-30 | C1C1111F5NWE-320, LOE-SUM1-240 FF | 119.75d | 22.5d |  |  | Helper [514.8 h] | 36.19 | Civil | NWE |
|  | 11 | **LOE Commodities Civil NWE ( B01 to B03)** |  |  | 2018-12-13 | 2019-04-15 |  |  |  |  |  |  |  |  |  |
| C1C1111F5NWE-350 |  | LOE - NWE B03 to B01 - Rebar | level of effort | 123.75d | 2018-12-13 | 2019-04-07 | C1C1111F5NWE-020 SS | 119.75d | 0d |  |  | Steel Reinforcement [546.03 tons] |  | Civil | NWE |
| C1C1111F5NWE-360 |  | LOE - NWE B03 to B01 - Formworks | level of effort | 126.25d | 2018-12-17 | 2019-04-13 | C1C1111F5NWE-030 SS | 119.75d | 0d |  |  | Formworks [5650.4 Square Meter] |  | Civil | NWE |
| C1C1111F5NWE-340 |  | LOE - NWE B03 to B01 - LOE - Mass concrete infill | level of effort | 121.25d | 2018-12-24 | 2019-04-15 | C1C1111F5NWE-040 SS | 119.75d | 0d |  |  | Concrete infill [330 CUM] |  | Civil | NEE |
|  | 5 | **ACY** |  |  | 2018-12-08 | 2019-05-26 |  |  |  |  |  |  |  |  |  |
|  | 1 | **ACY-2** |  |  | 2018-12-08 | 2019-04-20 |  |  |  |  |  |  |  |  |  |
| LOE-SUM1-250 |  | ACY-2 . Concrete Works | level of effort | 143.75d | 2018-12-08 | 2019-04-20 | C1C1111F5AY2-005 SS | 87.25d | 0d |  | Saudi |  |  | Civil |  |
|  | 1 | **Base Slab at Concourse Level B03 . ACY-2** |  |  | 2018-12-08 | 2019-02-02 |  |  |  |  |  |  |  |  |  |
| C1C1111F5AY2-005 |  | Base slab B03 . ACY-2 Excavation (not by ZSCC) |  | 15d | 2018-12-08 | 2018-12-20 | C1C1111F5N890 | 6.25d | 0d | start on or after 2018-12-08 |  |  |  | BACS | ACY2 |
| C1C1111F5AY2-010 |  | Base slab B03 . ACY-2 Waterproofing (not by ZSCC), Blinding |  | 5d | 2018-12-22 | 2018-12-25 | C1C1111F5AY2-005 | 6.25d | 0d |  |  |  |  | BACS | ACY2 |
| C1C1111F5AY2-020 |  | Base slab B03 . ACY-2 Rebar fixing |  | 6.25d | 2018-12-26 | 2018-12-31 | B750 FS+32.5d, C1C1111F5AY2-010 | 6.25d | 0d |  |  | Helper [386.1 h]; Steel Fixer [858 h] | 87.46 | Civil | ACY2 |
| C1C1111F5AY2-030 |  | Base slab B03 . ACY-2 Formwork fixing |  | 6.25d | 2019-01-01 | 2019-01-06 | C1C1111F5AY2-020 | 6.25d | 0d |  |  | Helper [214.5 h]; Carpenter [572 h] | 55.29 | Civil | ACY2 |
| C1C1111F5AY2-040 |  | Base slab B03 . ACY-2 Concrete Casting base slab |  | 2.5d | 2019-01-07 | 2019-01-08 | C1C1111F5AY2-030 | 6.25d | 0d |  |  | Concrete Casting [270.74 CUM]; Helper [143 h]; Mason [429 h] | 40.21 | Civil | ACY2 |

| ID | WBS | Activity | Duration | Start | Finish | Predecessors | Total float | Free float | Resources | Cost | Discipline | LOCATION |
| --- | --- | --- | --- | --- | --- | --- | --- | --- | --- | --- | --- | --- |
|  | 3 | **Outer & Inner Wall Concourse Level ( B03 . ACY 2 )** |  | 2019-01-09 | 2019-02-02 |  |  |  |  |  |  |  |
| C1C1111F5AY2-050 |  | B03. ACY-2 Waterproofing Wall (not by ZSCC) | 5d | 2019-01-09 | 2019-01-13 | C1C1111F5AY2-040 | 6.25d | 0d |  |  | Civil | ACY2 |
| C1C1111F5AY2-060 |  | B03. ACY-2 Rebar fixing wall | 6.25d | 2019-01-14 | 2019-01-19 | C1C1111F5AY2-050 | 6.25d | 0d | Helper [171.6 h]; Steel Fixer [715 h] | 62.32 | Civil | ACY2 |
| C1C1111F5AY2-070 |  | B03. ACY-2 Formwork fixing wall ( 1st Lift ) | 5d | 2019-01-20 | 2019-01-23 | C1C1111F5AY2-060 | 6.25d | 0d | Helper [143 h]; Carpenter [572 h] | 50.26 | Civil | ACY2 |
| C1C1111F5AY2-080 |  | B03. ACY-2 Concrete Casting & Striking wall ( 1st Lift - 25cm ) | 2.5d | 2019-01-24 | 2019-01-26 | C1C1111F5AY2-070 | 6.25d | 0d | Concrete Casting [28.41 CUM]; Helper [143 h]; Mason [343.2 h] | 34.18 | Civil | ACY2 |
| C1C1111F5AY2-090 |  | B03. ACY-2 Formwork fixing wall (2nd Lift) | 5d | 2019-01-27 | 2019-01-30 | C1C1111F5AY2-080 | 45d | 0d | Helper [214.5 h]; Carpenter [572 h] | 55.29 | Civil | ACY2 |
| C1C1111F5AY2-100 |  | B03. ACY-2 Concrete Casting & Striking wall (2nd Lift - 177cm) | 2.5d | 2019-01-31 | 2019-02-02 | C1C1111F5AY2-090 | 45d | 0d | Concrete Casting [101 CUM]; Helper [143 h]; Mason [429 h] | 40.21 | Civil | ACY2 |
|  | 8 | **TV Louver Level B02 . ACY-2** |  | 2019-02-03 | 2019-03-07 |  |  |  |  |  |  |  |
|  | 1 | **TV Louver Level ( B02 . ACY-2 )** |  | 2019-02-03 | 2019-03-07 |  |  |  |  |  |  |  |
| C1C1111F5AY2-110 |  | B02. ACY-2 Formwork and Slab fixing | 7.5d | 2019-02-03 | 2019-02-09 | C1C1111F5AY2-100 | 45d | 0d | Helper [343.2 h]; Carpenter [686.4 h] | 72.38 | Civil | ACY2 |
| C1C1111F5AY2-120 |  | B02. ACY-2 Rebar fixing | 7.5d | 2019-02-10 | 2019-02-16 | B770 FS+32.5d, C1C1111F5AY2-110 | 45d | 0d | Helper [343.2 h]; Steel Fixer [715 h] | 74.39 | Civil | ACY2 |
| C1C1111F5AY2-130 |  | B02. ACY-2 Concrete Casting Slab | 2.5d | 2019-02-17 | 2019-02-18 | C1C1111F5AY2-120 | 45d | 0d | Concrete Casting [90 CUM]; Helper [143 h]; Mason [514.8 h] | 46.24 | Civil | ACY2 |
| C1C1111F5AY2-140 |  | B02. ACY-2 Waterproofing wall (not by ZSCC) | 5d | 2019-02-19 | 2019-02-23 | C1C1111F5AY2-130 | 45d | 0d |  |  | Civil | ACY2 |
| C1C1111F5AY2-150 |  | B02. ACY-2 Rebar fixing wall / column / staircase | 6.25d | 2019-02-24 | 2019-02-28 | C1C1111F5AY2-140 | 45d | 0d | Helper [457.6 h]; Steel Fixer [715 h] | 82.43 | Civil | ACY2 |
| C1C1111F5AY2-160 |  | B02. ACY-2 Formwork fixing wall / column / staircase | 6.25d | 2019-02-28 | 2019-03-05 | C1C1111F5AY2-150 SS+5d | 45d | 0d | Helper [457.6 h]; Carpenter [715 h] | 82.43 | Civil | ACY2 |
| C1C1111F5AY2-170 |  | B02. ACY-2 Concrete Casting wall / column / staircase | 2.5d | 2019-03-06 | 2019-03-07 | C1C1111F5AY2-160 | 45d | 0d | Concrete Casting [366 CUM]; Helper [143 h]; Mason [429 h] | 40.21 | Civil | ACY2 |
|  | 9 | **Top Slab Level B01 . ACY-2** |  | 2019-03-09 | 2019-03-21 |  |  |  |  |  |  |  |
|  | 1 | **Top Slab Level ( B01 . ACY-2 )** |  | 2019-03-09 | 2019-03-21 |  |  |  |  |  |  |  |
| C1C1111F5AY2-180 |  | B01. ACY-2 Formwork and Slab fixing | 6.25d | 2019-03-09 | 2019-03-13 | C1C1111F5AY2-170 | 45d | 0d | Helper [286 h]; Carpenter [572 h] | 60.32 | Civil | ACY2 |
| C1C1111F5AY2-190 |  | B01. ACY-2 Rebar fixing | 6.25d | 2019-03-14 | 2019-03-19 | C1C1111F5AY2-180 | 45d | 0d | Helper [286 h]; Steel Fixer [572 h] | 60.32 | Civil | ACY2 |
| C1C1111F5AY2-200 |  | B01. ACY-2 Concrete Casting Slab | 2.5d | 2019-03-20 | 2019-03-21 | C1C1111F5AY2-190 | 45d | 0d | Concrete Casting [126.16 CUM]; Helper [143 h]; Mason [514.8 h] | 46.24 | Civil | ACY2 |
|  | 10 | **Paraphet Wall above Top Slab B01 . ACY-2** |  | 2019-03-23 | 2019-04-20 |  |  |  |  |  |  |  |
|  | 1 | **Paraphet Wall above Top Slab ( B01 . ACY 2)** |  | 2019-03-23 | 2019-04-20 |  |  |  |  |  |  |  |
| C1C1111F5AY2-220 |  | B01. ACY-2 Rebar fixing column / wall / staircase | 6.25d | 2019-03-23 | 2019-03-27 | B780 FS+32.5d, B790 FS+32.5d, C1C1111F5AY2-310 FF, C1C1111F5AY2-200 | 45d | 0d | Helper [286 h]; Steel Fixer [572 h] | 60.32 | Civil | ACY2 |
| C1C1111F5AY2-230 |  | B01. ACY-2 Formwork fixing column / wall/ staircase | 6.25d | 2019-03-28 | 2019-04-02 | C1C1111F5AY2-220, C1C1111F5AY2-320 FF | 45d | 0d | Helper [286 h]; Carpenter [572 h] | 60.32 | Civil | ACY2 |
| C1C1111F5AY2-250 |  | B01. ACY-2 Concrete Casting column / wall / staircase | 2.5d | 2019-04-03 | 2019-04-04 | C1C1111F5AY2-230, C1C1111F5AY2-300 FF | 45d | 0d | Concrete Casting [195.49 CUM]; Helper [143 h]; Mason [429 h] | 40.21 | Civil | ACY2 |
| C1C1111F5AY2-260 |  | B01. ACY-2 Waterproofing wall (not by ZSCC) | 5d | 2019-04-06 | 2019-04-09 | C1C1111F5AY2-250 | 83.5d | 0d |  |  | BACS | ACY2 |
| C1C1111F5AY2-270 |  | B01. ACY-2 Protection Screed | 3.75d | 2019-04-10 | 2019-04-13 | C1C1111F5AY2-260 | 83.5d | 0d | Mason [257.4 h]; Helper [128.7 h] | 27.15 | Civil | ACY2 |
| C1C1111F5AY2-280 |  | B01. ACY-2 Backfilling & compaction (Optional) | 7.5d | 2019-04-14 | 2019-04-20 | C1C1111F5AY2-270, LOE-SUM1-250 FF | 83.5d | 15d | Helper [514.8 h] | 36.19 | Civil | ACY2 |

| ID | WBS | Activity | Type | Duration | Start | Finish | Predecessors | Total float | Free float | Calendar | Resources | Cost | Discipline | LOCATION |
| --- | --- | --- | --- | --- | --- | --- | --- | --- | --- | --- | --- | --- | --- | --- |
|  | 11 | **LOE Commodities Civil ACY-2 ( B01 to B03)** |  |  | 2018-12-26 | 2019-04-04 |  |  |  |  |  |  |  |  |
| C1C1111F5AY2-310 |  | LOE - ACY-2 B03 to B01 - Rebar | level of effort | 98.75d | 2018-12-26 | 2019-03-27 | C1C1111F5AY2-020 SS | 45d | 0d |  | Steel Reinforcement [227.87 tons] |  | Civil | ACY2 |
| C1C1111F5AY2-320 |  | LOE - ACY-2 B03 to B01 - Formworks | level of effort | 98.75d | 2019-01-01 | 2019-04-02 | C1C1111F5AY2-030 SS | 45d | 0d |  | Formworks [2356.46 Square Meter] |  | Civil | ACY2 |
| C1C1111F5AY2-300 |  | LOE - ACY-2 B03 to B01 - LOE - Mass concrete infill | level of effort | 95d | 2019-01-07 | 2019-04-04 | C1C1111F5AY2-040 SS | 45d | 0d |  | Concrete infill [150 CUM] |  | Civil | NEE |
|  | 2 | **ACY-1** |  |  | 2019-01-27 | 2019-05-26 |  |  |  |  |  |  |  |  |
| LOE-SUM1-260 |  | ACY-1 . Concrete Works | level of effort | 128.75d | 2019-01-27 | 2019-05-26 | C1C1111F5AY1-010 SS | 107.25d | 0d | Saudi |  |  | Civil |  |
|  | 1 | **Base Slab at Concourse Level B03 . ACY-1** |  |  | 2019-01-27 | 2019-03-09 |  |  |  |  |  |  |  |  |
| C1C1111F5AY1-010 |  | Base slab B03 . ACY-1 Waterproofing (not by ZSCC), Blinding |  | 5d | 2019-01-27 | 2019-01-30 | C1C1111F5AY2-080, C1C1111F5AY2-010 SS+2.5d | 6.25d | 0d |  |  |  | Civil | ACY1 |
| C1C1111F5AY1-020 |  | Base slab B03 . ACY-1 Rebar fixing |  | 6.25d | 2019-01-31 | 2019-02-05 | C1C1111F5AY1-010 | 6.25d | 0d |  | Helper [386.1 h]; Steel Fixer [858 h] | 87.46 | Civil | ACY1 |
| C1C1111F5AY1-030 |  | Base slab B03 . ACY-1 Formwork fixing |  | 6.25d | 2019-02-06 | 2019-02-11 | C1C1111F5AY1-020 | 6.25d | 0d |  | Helper [214.5 h]; Carpenter [715 h] | 65.34 | Civil | ACY1 |
| C1C1111F5AY1-040 |  | Base slab B03 . ACY-1 Concrete Casting base slab |  | 2.5d | 2019-02-12 | 2019-02-13 | C1C1111F5AY1-030 | 6.25d | 0d |  | Concrete Casting [55.73 CUM]; Helper [143 h]; Mason [514.8 h] | 46.24 | Civil | ACY1 |
|  | 2 | **Outer & Inner Wall Concourse Level ( B03 . ACY-1 )** |  |  | 2019-02-14 | 2019-03-09 |  |  |  |  |  |  |  |  |
| C1C1111F5AY1-050 |  | B03. ACY-1 Waterproofing Wall (not by ZSCC) |  | 5d | 2019-02-14 | 2019-02-18 | C1C1111F5AY1-040 | 6.25d | 0d |  |  |  | Civil | ACY1 |
| C1C1111F5AY1-060 |  | B03. ACY-1 Rebar fixing wall |  | 5d | 2019-02-19 | 2019-02-23 | C1C1111F5AY1-050 | 6.25d | 0d |  | Helper [171.6 h]; Steel Fixer [572 h] | 52.27 | Civil | ACY1 |
| C1C1111F5AY1-070 |  | B03. ACY-1 Formwork fixing wall ( 1st Lift ) |  | 5d | 2019-02-24 | 2019-02-27 | C1C1111F5AY1-060 | 6.25d | 0d |  | Carpenter [572 h]; Helper [143 h] | 50.26 | Civil | ACY1 |
| C1C1111F5AY1-080 |  | B03. ACY-1 Concrete Casting & Striking wall ( 1st Lift ) |  | 2.5d | 2019-02-28 | 2019-03-02 | C1C1111F5AY1-070 | 6.25d | 0d |  | Concrete Casting [273.71 CUM]; Helper [143 h]; Mason [286 h] | 30.16 | Civil | ACY1 |
| C1C1111F5AY1-090 |  | B03. ACY-1 Formwork fixing wall (2nd Lift) |  | 5d | 2019-03-03 | 2019-03-06 | C1C1111F5AY1-080 | 6.25d | 0d |  | Helper [214.5 h]; Carpenter [572 h] | 55.29 | Civil | ACY1 |
| C1C1111F5AY1-100 |  | B03. ACY-1 Concrete Casting & Striking wall (2nd Lift) |  | 2.5d | 2019-03-07 | 2019-03-09 | C1C1111F5AY1-090 | 6.25d | 0d |  | Concrete Casting [179.77 CUM]; Helper [143 h]; Mason [429 h] | 40.21 | Civil | ACY1 |
|  | 3 | **TV Louver Level B02 . ACY-1** |  |  | 2019-03-10 | 2019-04-09 |  |  |  |  |  |  |  |  |
|  | 1 | **TV Louver Level ( B02 . ACY-1 )** |  |  | 2019-03-10 | 2019-04-09 |  |  |  |  |  |  |  |  |
| C1C1111F5AY1-110 |  | B02. ACY-1 Formwork and Slab fixing |  | 6.25d | 2019-03-10 | 2019-03-14 | C1C1111F5AY1-100 | 6.25d | 0d |  | Helper [343.2 h]; Carpenter [858 h] | 84.45 | Civil | ACY1 |
| C1C1111F5AY1-120 |  | B02. ACY-1 Rebar fixing |  | 6.25d | 2019-03-16 | 2019-03-20 | C1C1111F5AY1-110 | 6.25d | 0d |  | Helper [343.2 h]; Steel Fixer [715 h] | 74.39 | Civil | ACY1 |
| C1C1111F5AY1-130 |  | B02. ACY-1 Concrete Casting Slab |  | 2.5d | 2019-03-21 | 2019-03-23 | C1C1111F5AY1-120 | 6.25d | 0d |  | Concrete Casting [25.17 CUM]; Helper [143 h]; Mason [514.8 h] | 46.24 | Civil | ACY1 |
| C1C1111F5AY1-140 |  | B02. ACY-1 Waterproofing wall (not by ZSCC) |  | 5d | 2019-03-24 | 2019-03-27 | C1C1111F5AY1-130 | 6.25d | 0d |  |  |  | Civil | ACY1 |
| C1C1111F5AY1-150 |  | B02. ACY-1 Rebar fixing wall / column / staircase |  | 6.25d | 2019-03-28 | 2019-04-02 | C1C1111F5AY1-140 | 6.25d | 0d |  | Helper [286 h]; Steel Fixer [572 h] | 60.32 | Civil | ACY1 |
| C1C1111F5AY1-160 |  | B02. ACY-1 Formwork fixing wall / column / staircase |  | 6.25d | 2019-04-02 | 2019-04-07 | C1C1111F5AY1-150 SS+5d | 6.25d | 0d |  | Helper [286 h]; Carpenter [572 h] | 60.32 | Civil | ACY1 |
| C1C1111F5AY1-170 |  | B02. ACY-1 Concrete Casting wall / column / staircase |  | 2.5d | 2019-04-08 | 2019-04-09 | C1C1111F5AY1-160 | 6.25d | 0d |  | Helper [143 h]; Mason [429 h]; Concrete Casting [102.47 CUM] | 40.21 | Civil | ACY1 |

| ID | WBS | Activity | Type | Duration | Start | Finish | Predecessors | Total float | Free float | Calendar | Resources | Cost | Discipline | LOCATION |
| --- | --- | --- | --- | --- | --- | --- | --- | --- | --- | --- | --- | --- | --- | --- |
|  | 4 | **Top Slab Level B01 . ACY-1** |  |  | 2019-04-10 | 2019-04-25 |  |  |  |  |  |  |  |  |
|  | 1 | **Top Slab Level ( B01 . ACY-1 )** |  |  | 2019-04-10 | 2019-04-25 |  |  |  |  |  |  |  |  |
| C1C1111F5AY1-180 |  | B01. AACY-1 Formwork and Slab fixing |  | 7.5d | 2019-04-10 | 2019-04-16 | C1C1111F5AY1-170 | 6.25d | 0d |  | Helper [343.2 h]; Carpenter [715 h] | 74.39 | Civil | ACY1 |
| C1C1111F5AY1-190 |  | B01. ACY-1 Rebar fixing |  | 7.5d | 2019-04-17 | 2019-04-23 | C1C1111F5AY1-180 | 6.25d | 0d |  | Helper [343.2 h]; Steel Fixer [715 h] | 74.39 | Civil | ACY1 |
| C1C1111F5AY1-200 |  | B01. ACY-1 Concrete Casting Slab |  | 2.5d | 2019-04-24 | 2019-04-25 | C1C1111F5AY1-190 | 6.25d | 0d |  | Concrete Casting [111.51 CUM]; Helper [143 h]; Mason [514.8 h] | 46.24 | Civil | ACY1 |
|  | 5 | **Paraphet Wall above Top Slab B01 . ACY-1** |  |  | 2019-04-27 | 2019-05-26 |  |  |  |  |  |  |  |  |
|  | 1 | **Paraphet Wall above Top Slab ( B01 . ACY-1)** |  |  | 2019-04-27 | 2019-05-26 |  |  |  |  |  |  |  |  |
| C1C1111F5AY1-220 |  | B01. ACY-1 Rebar fixing column / wall / staircase |  | 7.5d | 2019-04-27 | 2019-05-02 | C1C1111F5AY1-200, B750 FS+50d, C1C1111F5AY1-310 FF, B790 FS+50d | 6.25d | 0d |  | Helper [400.4 h]; Steel Fixer [715 h] | 78.41 | Civil | ACY1 |
| C1C1111F5AY1-230 |  | B01. ACY-1 Formwork fixing column / wall/ staircase |  | 6.25d | 2019-05-04 | 2019-05-08 | C1C1111F5AY1-220, C1C1111F5AY1-320 FF | 6.25d | 0d |  | Helper [343.2 h]; Carpenter [715 h] | 74.39 | Civil | ACY1 |
| C1C1111F5AY1-240 |  | B01. ACY-1 Concrete Casting column / wall / staircase |  | 2.5d | 2019-05-09 | 2019-05-11 | C1C1111F5AY2-250 FF, C1C1111F5AY1-230, C1C1111F5AY1-300 FF | 6.25d | 0d |  | Concrete Casting [104.08 CUM]; Helper [143 h]; Mason [429 h] | 40.21 | Civil | ACY1 |
| C1C1111F5AY1-250 |  | B01. ACY-1 Waterproofing wall (not by ZSCC) |  | 5d | 2019-05-12 | 2019-05-15 | C1C1111F5AY1-240 | 99.75d | 0d |  |  |  | Civil | ACY1 |
| C1C1111F5AY1-260 |  | B01. ACY-1 Protection Screed |  | 3.75d | 2019-05-16 | 2019-05-19 | C1C1111F5AY1-250 | 99.75d | 0d |  | Mason [257.4 h]; Helper [128.7 h] | 27.15 | Civil | ACY1 |
| C1C1111F5AY1-270 |  | B01. ACY-1 Backfilling & compaction (Optional) |  | 7.5d | 2019-05-20 | 2019-05-26 | C1C1111F5AY1-260, C1C1111F5AY2-280, LOE-SUM1-260 FF | 99.75d | 18.75d |  | Helper [514.8 h] | 36.19 | Civil | ACY1 |
|  | 11 | **LOE Commodities Civil ACY-1 ( B01 to B03)** |  |  | 2019-01-31 | 2019-05-11 |  |  |  |  |  |  |  |  |
| C1C1111F5AY1-310 |  | LOE - ACY-1 B03 to B01 - Rebar | level of effort | 98.75d | 2019-01-31 | 2019-05-02 | C1C1111F5AY1-020 SS | 6.25d | 0d |  | Steel Reinforcement [166.82 tons] |  | Civil | ACY1 |
| C1C1111F5AY1-320 |  | LOE - ACY-1 B03 to B01 - Formworks | level of effort | 98.75d | 2019-02-06 | 2019-05-08 | C1C1111F5AY1-030 SS | 6.25d | 0d |  | Formworks [1722.4 Square Meter] |  | Civil | ACY1 |
| C1C1111F5AY1-300 |  | LOE - ACY-1 B03 to B01- LOE - Mass concrete infill | level of effort | 95d | 2019-02-12 | 2019-05-11 | C1C1111F5AY1-040 SS | 6.25d | 0d |  | Concrete infill [100 CUM] |  | Civil | NEE |
|  | 2 | **STRUCTURAL METAL WORKS** |  |  | 2019-01-30 | 2019-06-18 |  |  |  |  |  |  |  |  |
|  | 4 | **CONSTRUCTION / STEEL ERECTION** |  |  | 2019-01-30 | 2019-06-18 |  |  |  |  |  |  |  |  |
| LOE-SUM1-270 |  | Strucl Steel Works | level of effort | 150d | 2019-01-30 | 2019-06-18 | 1F5-SMW-010 SS | 99.75d | 0d | Saudi |  |  | Arch'l |  |
|  | 1 | **Priority 1: PSD (17.7 tons appx)** |  |  | 2019-01-30 | 2019-02-28 |  |  |  |  |  |  |  |  |
| 1F5-SMW-010 |  | Site preparation / Scaffolding / Member sorting |  | 15d | 2019-01-30 | 2019-02-12 | 1F5-FNS-B05-870 | 96d | 0d |  | Unskilled Labour [240 h]; Skilled Labour [360 h] | 45.73 | Arch'l |  |
| 1F5-SMW-020 |  | Erection of PSD |  | 32.5d | 2019-01-30 | 2019-02-28 | 1F5-SMW-010 SS, 1F5-SMW-010 FF | 98.5d | 2.5d |  | Unskilled Labour [260 h]; Skilled Labour [780 h] | 79.25 | Arch'l |  |
|  | 2 | **Priority 2: Two Passenger Lift (8.5 tons appx)** |  |  | 2019-02-13 | 2019-03-20 |  |  |  |  |  |  |  |  |
| 1F5-SMW-030 |  | Site preparation / Scaffolding / Member sorting |  | 12.5d | 2019-02-13 | 2019-02-24 | 1F5-SMW-010 | 96d | 0d |  | Unskilled Labour [100 h]; Skilled Labour [300 h] | 30.48 | Arch'l |  |
| 1F5-SMW-040 |  | Erection of Two Core of Passenger Lift |  | 32.5d | 2019-02-19 | 2019-03-20 | 1F5-SMW-030 SS+6.25d, 1F5-SMW-020 SS+18.75d | 96d | 0d |  | Skilled Labour [780 h]; Unskilled Labour [260 h] | 79.25 | Arch'l |  |

| ID | WBS | Activity | Type | Duration | Start | Finish | Predecessors | Total float | Free float | Calendar | Resources | Cost | Discipline | 1F4 PROJECT | AREA | LOCATION |
| --- | --- | --- | --- | --- | --- | --- | --- | --- | --- | --- | --- | --- | --- | --- | --- | --- |
|  | 3 | **Priority 3: Curtain (5.4 tons appx)** |  |  | 2019-03-21 | 2019-04-20 |  |  |  |  |  |  |  |  |  |  |
| 1F5-SMW-050 |  | Site preparation / Scaffolding / Member sorting |  | 12.5d | 2019-03-21 | 2019-04-01 | 1F5-SMW-040, 1F5-SMW-030 | 96d | 0d |  | Skilled Labour [300 h]; Unskilled Labour [100 h] | 30.48 | Arch'l |  |  |  |
| 1F5-SMW-060 |  | Erection of Curtain |  | 30d | 2019-03-24 | 2019-04-20 | 1F5-SMW-020, 1F5-SMW-040, 1F5-SMW-050 SS+2.5d | 96d | 0d |  | Skilled Labour [720 h]; Unskilled Labour [240 h] | 73.16 | Arch'l |  |  |  |
|  | 4 | **Priority 4: Steel At ACY-2 (6.7 tons appx)** |  |  | 2019-04-02 | 2019-05-01 |  |  |  |  |  |  |  |  |  |  |
| 1F5-SMW-070 |  | Site preparation / Scaffolding / Member sorting |  | 10d | 2019-04-02 | 2019-04-10 | 1F5-SMW-050 | 101d | 5d |  | Unskilled Labour [80 h]; Skilled Labour [240 h] | 24.39 | Arch'l |  |  |  |
| 1F5-SMW-080 |  | Erection of Steel at ACY-2 |  | 27.5d | 2019-04-07 | 2019-05-01 | 1F5-SMW-060 SS+15d, 1F5-SMW-040, 1F5-SMW-070 SS | 96d | 0d |  | Skilled Labour [660 h]; Unskilled Labour [220 h] | 67.07 | Arch'l |  |  |  |
|  | 5 | **Priority 5: Ceiling Steel Frame (9.3 tons appx)** |  |  | 2019-04-21 | 2019-05-18 |  |  |  |  |  |  |  |  |  |  |
| 1F5-SMW-090 |  | Erection of Ceiling Steel Frame |  | 30d | 2019-04-21 | 2019-05-18 | 1F5-SMW-080 SS+15d | 96d | 0d |  | Skilled Labour [720 h]; Unskilled Labour [240 h] | 73.16 | Arch'l |  |  |  |
|  | 6 | **Priority 6: Misc Steel (13.93 tons appx)** |  |  | 2019-05-02 | 2019-06-01 |  |  |  |  |  |  |  |  |  |  |
| 1F5-SMW-100 |  | Erection of Misc Steel |  | 32.5d | 2019-05-02 | 2019-06-01 | 1F5-SMW-090 SS, 1F5-SMW-080 | 98.5d | 0d |  | Skilled Labour [1040 h]; Unskilled Labour [1040 h] | 158.52 | Arch'l |  |  |  |
|  | 7 | **Priority 7: Three Lifts at Entances (14.4 tons appx)** |  |  | 2019-05-16 | 2019-06-18 |  |  |  |  |  |  |  |  |  |  |
| 1F5-SMW-110 |  | Site preparation / Scaffolding / Member sorting |  | 10d | 2019-05-16 | 2019-05-25 | 1F5-SMW-100 SS+15d | 98.5d | 2.5d |  | Skilled Labour [240 h]; Unskilled Labour [80 h] | 24.39 | Arch'l |  |  |  |
| 1F5-SMW-120 |  | Erection of Core of Three Passenger Lifts |  | 30d | 2019-05-19 | 2019-06-18 | 1F5-SMW-100 SS+15d, 1F5-SMW-110 SS, 1F5-SMW-090, LOE-SUM1-270 FF | 96d | 0d |  | Skilled Labour [960 h]; Unskilled Labour [960 h] | 146.32 | Arch'l |  |  |  |
|  | 3 | **ARCHL WORKS** |  |  | 2018-12-16 | 2019-12-19 |  |  |  |  |  |  |  |  |  |  |
|  | 1 | **ARCHL WORKS at MAIN BOX** |  |  | 2018-12-16 | 2019-12-15 |  |  |  |  |  |  |  |  |  |  |
|  | 1 | **PLATFORM LEVEL (P06 )** |  |  | 2018-12-16 | 2019-10-26 |  |  |  |  |  |  |  |  |  |  |
| LOE-SUM2-010 |  | South . P06 . Siemens Rooms - Archl Works | level of effort | 169d | 2018-12-16 | 2019-05-22 | 1F5-FNS-P06-010 SS | 1d | 0d | Saudi |  |  | Arch'l |  |  |  |
| LOE-SUM2-040 |  | Central . P06 . Siemens Rooms - Archl Works | level of effort | 155.75d | 2019-01-02 | 2019-05-27 | 1F5-FNS-P06-450 SS | 34.25d | 0d | Saudi |  |  | Arch'l |  |  |  |
| LOE-SUM2-060 |  | North . P06 . Siemens Rooms - Archl Works | level of effort | 180.75d | 2019-01-06 | 2019-06-23 | 1F5-FNS-P06-670 SS | 14.25d | 0d | Saudi |  |  | Arch'l |  |  |  |
| LOE-SUM2-020 |  | South . P06 . BOH / FOH - Archl Works | level of effort | 234d | 2019-01-24 | 2019-08-31 | 1F5-FNS-P06-100 SS | 142.25d | 0d | Saudi |  |  | Arch'l |  |  |  |
| LOE-SUM2-070 |  | North . P06 . BOH / FOH - Archl Works | level of effort | 235.5d | 2019-03-20 | 2019-10-26 | 1F5-FNS-P06-760 SS | 93.25d | 0d | Saudi |  |  | Arch'l |  |  |  |
| LOE-SUM2-050 |  | Central . P06 . BOH / FOH - Archl Works | level of effort | 185.5d | 2019-04-22 | 2019-10-12 | 1F5-FNS-P06-540 SS | 100.75d | 0d | Saudi |  |  | Arch'l |  |  |  |
|  | 2 | **P06 . AREA-5** |  |  | 2018-12-16 | 2019-08-27 |  |  |  |  |  |  |  |  |  |  |
|  | 3 | **SIEMENS ROOM** |  |  | 2018-12-16 | 2019-05-19 |  |  |  |  |  |  |  |  |  |  |
|  | 1 | **Wet Finishes** |  |  | 2018-12-16 | 2019-05-19 |  |  |  |  |  |  |  |  |  |  |
| 1F5-FNS-P06-010 |  | P06 . AREA-5 . SR - Block Masonry |  | 15d | 2018-12-16 | 2018-12-29 | C1C1111F5S920 FS+7.5d, 1F5-ARDWG560 | 1d | 0d |  | Unskilled Labour [514.8 h]; Skilled Labour [858 h] | 104.62 | Arch'l | 1F4CVL | 5 | MB |
| 1F5-FNS-P06-020 |  | P06 . AREA-5 . SR - Interior Plaster & Rendering |  | 10d | 2018-12-27 | 2019-01-05 | 1F5-FNS-P06-010 FF+7.5d, 1F5-PRO-GN-430 SS, 1F5-ARDWG570 | 1d | 0d |  | Skilled Labour [457.6 h]; Unskilled Labour [228.8 h] | 52.31 | Arch'l | 1F4CVL | 5 | MB |
| 1F5-FNS-P06-030 |  | P06 . AREA-5 . SR - Ceiling Painting 1st Coat |  | 5d | 2019-01-06 | 2019-01-09 | 1F5-FNS-P06-010, 1F5-FNS-P06-020 | 1d | 0d |  | Skilled Labour [171.6 h]; Unskilled Labour [114.4 h] | 21.8 | Arch'l | 1F4CVL | 5 | MB |
| 1F5-FNS-P06-040 |  | P06 . AREA-5 . SR - Walls Painting 1st Coat |  | 5d | 2019-01-10 | 2019-01-14 | 1F5-FNS-P06-020, 1F5-FNS-P06-030 | 1d | 0d |  | Skilled Labour [228.8 h]; Unskilled Labour [171.6 h] | 30.52 | Arch'l | 1F4CVL | 5 | MB |
| 1F5-FNS-P06-050 |  | P06 . AREA-5 . SR - Floor Concreted Screeding |  | 10d | 2019-01-15 | 2019-01-23 | 1F5-FNS-P06-040 FF+3.75d, 1F5-FNS-P06-040, 1F5-FNS-P06-030, 1F5-ARDWG590 | 1d | 0d |  | Unskilled Labour [343.2 h]; Skilled Labour [686.4 h] | 78.47 | Arch'l | 1F4CVL | 5 | MB |

| ID | WBS | Activity | Duration | Start | Finish | Predecessors | Total float | Free float | Resources | Cost | 1F4 PROJECT | Discipline | AREA | LOCATION |
| --- | --- | --- | --- | --- | --- | --- | --- | --- | --- | --- | --- | --- | --- | --- |
|  | 2 | **Final finishes prior to Handing over to Siemens** |  | 2019-05-01 | 2019-05-19 |  |  |  |  |  |  |  |  |  |
| 1F5-FNS-P06-060A |  | P06 . AREA-5 . SR - Ceiling Final Painting | 5d | 2019-05-01 | 2019-05-06 | MR315, 1F5-FNS-P06-050 | 1d | 0d | Skilled Labour [171.6 h]; Unskilled Labour [171.6 h] | 26.16 | 1F4CVL | Arch'l | 5 | MB |
| 1F5-FNS-P06-070 |  | P06 . AREA-5 . SR - Walls Final Painting | 5d | 2019-05-06 | 2019-05-11 | 1F5-FNS-P06-050 FF+2.5d, MR315, 1F5-FNS-P06-030 FS+47.5d, 1F5-FNS-P06-060A | 1d | 0d | Unskilled Labour [171.6 h]; Skilled Labour [171.6 h] | 26.16 | 1F4CVL | Arch'l | 5 | MB |
| 1F5-FNS-P06-080 |  | P06 . AREA-5 . SR - Floor Final finishes | 5d | 2019-05-11 | 2019-05-15 | 1F5-FNS-P06-060A, 1F5-FNS-P06-070, 1F5-FNS-P06-050, 1F5-FNS-P06-060A FF+2.5d | 1d | 0d | Skilled Labour [171.6 h]; Unskilled Labour [114.4 h] | 21.8 | 1F4CVL | Arch'l | 5 | MB |
| 1F5-FNS-P06-090 |  | P06 . AREA-5 . SR -Install Door & Hardware/Accessories | 3.75d | 2019-05-15 | 2019-05-19 | 1F5-PRO-GN-520, 1F5-FNS-P06-080 FF, 1F5-PRO-GN-510, 1F5-FNS-P06-080, 1F5-ARDWG620 | 1d | 0d | Skilled Labour [85.8 h]; Unskilled Labour [57.2 h] | 10.9 | 1F4CVL | Arch'l | 5 | MB |
|  | 1 | **BOH / FOH (incl under Platform)** |  | 2019-01-24 | 2019-08-27 |  |  |  |  |  |  |  |  |  |
| 1F5-FNS-P06-100 |  | P06 . AREA-5 -Block Masonry | 15d | 2019-01-24 | 2019-02-06 | 1F5-FNS-P06-050, 1F5-FNS-P06-010, C1C1111F5S920 FS+22.5d | 62.25d | 0d | Unskilled Labour [429 h]; Skilled Labour [686.4 h] | 85 | 1F4CVL | Arch'l | 5 | MB |
| 1F5-FNS-P06-110 |  | P06 . AREA-5 -Interior Plaster & Rendering | 12.5d | 2019-02-02 | 2019-02-12 | 1F5-FNS-P06-100 FF+6.25d | 62.25d | 0d | Skilled Labour [429 h]; Unskilled Labour [257.4 h] | 52.31 | 1F4CVL | Arch'l | 5 | MB |
| 1F5-FNS-P06-120 |  | P06 . AREA-5 -Gypsum Partition and Panel | 7.5d | 2019-02-13 | 2019-02-19 | 1F5-ARDWG600, 1F5-FNS-P06-110 | 62.25d | 0d | Skilled Labour [257.4 h]; Unskilled Labour [85.8 h] | 26.16 |  | Arch'l | 5 | MB |
| 1F5-FNS-P06-130 |  | P06 . AREA-5 -Ceiling Painting 1st Coat | 6.25d | 2019-02-20 | 2019-02-25 | 1F5-FNS-P06-120, 1F5-FNS-P06-100 | 62.25d | 0d | Skilled Labour [178.75 h]; Unskilled Labour [143 h] | 24.52 | 1F4CVL | Arch'l | 5 | MB |
| 1F5-FNS-P06-140 |  | P06 . AREA-5 -Walls Painting 1st Coat | 7.5d | 2019-02-26 | 2019-03-04 | 1F5-FNS-P06-130, 1F5-FNS-P06-110 FS+2.5d | 62.25d | 0d | Skilled Labour [214.5 h]; Unskilled Labour [214.5 h] | 32.7 | 1F4CVL | Arch'l | 5 | MB |
| 1F5-FNS-P06-150 |  | P06 . AREA-5 -Floor Concreted Screeding | 7.5d | 2019-03-02 | 2019-03-07 | 1F5-FNS-P06-140 SS+3.75d, 1F5-FNS-P06-3030 FF | 62.25d | 0d | Unskilled Labour [171.6 h]; Skilled Labour [171.6 h] | 26.16 | 1F4CVL | Arch'l | 5 | MB |
| 1F5-FNS-P06-170 |  | P06 . AREA-5 -Raised Flooring | 6.25d | 2019-03-31 | 2019-04-04 | 1F5-PRO-GN-490, 1F5-FNS-P06-150 | 231.25d | 8.75d | Skilled Labour [171.6 h]; Unskilled Labour [57.2 h] | 17.44 | 1F4CVL | Arch'l | 5 | MB |
| 1F5-FNS-P06-160 |  | P06 . AREA-5 -Install Ceiling | 10d | 2019-04-04 | 2019-04-13 | 1F5-FNS-P06-150, 1F5-FNS-P06-140, 1F5-FNS-P06-130, 1F5-PRO-GN-470 | 222.5d | 0d | Unskilled Labour [171.6 h]; Skilled Labour [228.8 h] | 30.52 | 1F4CVL | Arch'l | 5 | MB |
| 1F5-FNS-P06-180 |  | P06 . AREA-5 -Install Floor Tiles | 7.5d | 2019-04-14 | 2019-04-20 | 1F5-FNS-P06-160, 1F5-FNS-P06-170, 1F5-PRO-GN-500, 1F5-PRO-GN-450, 1F5-PRO-GN-460 | 222.5d | 105.25d | Skilled Labour [257.4 h]; Unskilled Labour [128.7 h] | 29.43 | 1F4CVL | Arch'l | 5 | MB |
| 1F5-FNS-P06-190 |  | P06 . AREA-5 -Ceiling Final Painting | 7.5d | 2019-07-31 | 2019-08-07 | 1F5-FNS-P06-180, MR600, 1F5-FNS-P06-130, MR310, 1F5-PRO-GN-480 | 117.25d | 0d | Skilled Labour [214.5 h]; Unskilled Labour [128.7 h] | 26.16 | 1F4CVL | Arch'l | 5 | MB |
| 1F5-FNS-P06-200 |  | P06 . AREA-5 -Walls Final Painting | 7.5d | 2019-08-07 | 2019-08-18 | 1F5-FNS-P06-190, 1F5-FNS-P06-160, MR610, 1F5-FNS-P06-180, 1F5-PRO-GN-530 | 117.25d | 0d | Unskilled Labour [128.7 h]; Skilled Labour [214.5 h] | 26.16 | 1F4CVL | Arch'l | 5 | MB |
| 1F5-FNS-P06-210 |  | P06 . AREA-5 -Floor Epoxy Painting | 6.25d | 2019-08-18 | 2019-08-24 | 1F5-FNS-P06-190, MR600, 1F5-FNS-P06-150, 1F5-FNS-P06-200 | 140.75d | 0d | Skilled Labour [143 h]; Unskilled Labour [143 h] | 21.8 | 1F4CVL | Arch'l | 5 | MB |
| 1F5-FNS-P06-220 |  | P06 . AREA-5 -Install Door & Hardware/Accessories | 3.75d | 2019-08-24 | 2019-08-27 | 1F5-FNS-P06-210, 1F5-PRO-GN-520 FF, 1F5-PRO-GN-510 FF, 1F5-FNS-P06-090, 1F5-PRO-GN-530, 1F5-PRO-GN-440, 1F5-PRO-GN-520 | 140.75d | 0d | Skilled Labour [57.2 h]; Unskilled Labour [57.2 h] | 8.72 | 1F4CVL | Arch'l | 5 | MB |
|  | 1 | **P06 . AREA-4** |  | 2018-12-19 | 2019-08-31 |  |  |  |  |  |  |  |  |  |
|  | 3 | **SIEMENS ROOM** |  | 2018-12-19 | 2019-05-22 |  |  |  |  |  |  |  |  |  |
|  | 1 | **Wet Finishes** |  | 2018-12-19 | 2019-05-22 |  |  |  |  |  |  |  |  |  |
| 1F5-FNS-P06-230 |  | P06 . AREA-4 . SR - Block Masonry | 15d | 2018-12-19 | 2019-01-01 | 1F5-FNS-P06-010 SS+3.75d | 4.25d | 0d | Unskilled Labour [514.8 h]; Skilled Labour [1029.6 h] | 117.7 | 1F4CVL | Arch'l | 4 | MB |
| 1F5-FNS-P06-240 |  | P06 . AREA-4 . SR - Interior Plaster & Rendering | 10d | 2018-12-30 | 2019-01-07 | 1F5-FNS-P06-230 FF+6.25d | 4.25d | 0d | Skilled Labour [457.6 h]; Unskilled Labour [228.8 h] | 52.31 | 1F4CVL | Arch'l | 4 | MB |
| 1F5-FNS-P06-250 |  | P06 . AREA-4 . SR - Ceiling Painting 1st Coat | 5d | 2019-01-08 | 2019-01-12 | 1F5-FNS-P06-230, 1F5-FNS-P06-240 | 4.25d | 0d | Skilled Labour [171.6 h]; Unskilled Labour [114.4 h] | 21.8 | 1F4CVL | Arch'l | 4 | MB |
| 1F5-FNS-P06-260 |  | P06 . AREA-4 . SR - Walls Painting 1st Coat | 5d | 2019-01-13 | 2019-01-16 | 1F5-FNS-P06-250, 1F5-FNS-P06-240 | 4.25d | 0d | Skilled Labour [228.8 h]; Unskilled Labour [171.6 h] | 30.52 | 1F4CVL | Arch'l | 4 | MB |
| 1F5-FNS-P06-270 |  | P06 . AREA-4 . SR - Floor Concreted Screeding | 10d | 2019-01-17 | 2019-01-26 | 1F5-FNS-P06-260, 1F5-FNS-P06-250, 1F5-FNS-P06-260 SS | 4.25d | 0d | Unskilled Labour [343.2 h]; Skilled Labour [686.4 h] | 78.47 | 1F4CVL | Arch'l | 4 | MB |

| ID | WBS | Activity | Duration | Start | Finish | Predecessors | Total float | Free float | Resources | Cost | 1F4 PROJECT | Discipline | AREA | LOCATION |
| --- | --- | --- | --- | --- | --- | --- | --- | --- | --- | --- | --- | --- | --- | --- |
|  | 2 | **Final finishes prior to Handing over to Siemens** |  | 2019-01-27 | 2019-05-22 |  |  |  |  |  |  |  |  |  |
| 1F5-FNS-P06-280 |  | P06 . AREA-4 . SR - Ceiling Final Painting | 5d | 2019-01-27 | 2019-01-30 | 1F5-FNS-P06-270 | 106.25d | 41d | Skilled Labour [171.6 h]; Unskilled Labour [171.6 h] | 26.16 | 1F4CVL | Arch'l | 4 | MB |
| 1F5-FNS-P06-290 |  | P06 . AREA-4 . SR - Walls Final Painting | 5d | 2019-04-22 | 2019-04-27 | MR305 FF+5d, 1F5-FNS-P06-280 | 19.25d | 0d | Unskilled Labour [171.6 h]; Skilled Labour [171.6 h] | 26.16 | 1F4CVL | Arch'l | 4 | MB |
| 1F5-FNS-P06-300 |  | P06 . AREA-4 . SR - Floor Final finishes | 5d | 2019-04-27 | 2019-05-01 | 1F5-FNS-P06-270, 1F5-FNS-P06-290, 1F5-FNS-P06-280 | 19.25d | 18.25d | Skilled Labour [171.6 h]; Unskilled Labour [114.4 h] | 21.8 | 1F4CVL | Arch'l | 4 | MB |
| 1F5-FNS-P06-305 |  | P06 . AREA-4 . SR -Install Door & Hardware/Accessories | 3.75d | 2019-05-19 | 2019-05-22 | 1F5-FNS-P06-300, 1F5-FNS-P06-090, LOE-SUM2-010 FF | 1d | 0d | Skilled Labour [85.8 h]; Unskilled Labour [57.2 h] | 10.9 | 1F4CVL | Arch'l | 4 | MB |
|  | 1 | **BOH / FOH (incl under Platform)** |  | 2019-03-09 | 2019-08-31 |  |  |  |  |  |  |  |  |  |
| 1F5-FNS-P06-320 |  | P06 . AREA-4 -Block Masonry | 15d | 2019-03-09 | 2019-03-21 | 1F5-FNS-P06-150, C1C1111F5S820 FS+22.5d, 1F5-FNS-P06-010, 1F5-FNS-P06-240 | 62.25d | 0d | Unskilled Labour [429 h]; Skilled Labour [686.4 h] | 85 | 1F4CVL | Arch'l | 4 | MB |
| 1F5-FNS-P06-330 |  | P06 . AREA-4 -Interior Plaster & Rendering | 12.5d | 2019-03-14 | 2019-03-25 | 1F5-FNS-P06-320 FF+3.75d | 62.25d | 0d | Skilled Labour [429 h]; Unskilled Labour [257.4 h] | 52.31 | 1F4CVL | Arch'l | 4 | MB |
| 1F5-FNS-P06-340 |  | P06 . AREA-4 -Gypsum Partition and Panel | 7.5d | 2019-03-26 | 2019-04-01 | 1F5-FNS-P06-330 | 62.25d | 0d | Skilled Labour [257.4 h]; Unskilled Labour [85.8 h] | 26.16 |  | Arch'l | 4 | MB |
| 1F5-FNS-P06-350 |  | P06 . AREA-4 -Ceiling Painting 1st Coat | 6.25d | 2019-04-02 | 2019-04-07 | 1F5-FNS-P06-340, 1F5-FNS-P06-340 FF+3.75d, 1F5-FNS-P06-320 | 62.25d | 0d | Skilled Labour [178.75 h]; Unskilled Labour [143 h] | 24.52 | 1F4CVL | Arch'l | 4 | MB |
| 1F5-FNS-P06-360 |  | P06 . AREA-4 -Walls Painting 1st Coat | 7.5d | 2019-04-08 | 2019-04-14 | 1F5-FNS-P06-350, 1F5-FNS-P06-330 FS+2.5d | 62.25d | 0d | Skilled Labour [214.5 h]; Unskilled Labour [214.5 h] | 32.7 | 1F4CVL | Arch'l | 4 | MB |
| 1F5-FNS-P06-370 |  | P06 . AREA-4 -Floor Concreted Screeding | 7.5d | 2019-04-15 | 2019-04-21 | 1F5-FNS-P06-360 | 62.25d | 0d | Unskilled Labour [171.6 h]; Skilled Labour [171.6 h] | 26.16 | 1F4CVL | Arch'l | 4 | MB |
| 1F5-FNS-P06-380 |  | P06 . AREA-4 -Raised Flooring | 6.25d | 2019-04-22 | 2019-04-27 | 1F5-FNS-P06-370 | 183.75d | 0d | Skilled Labour [171.6 h]; Unskilled Labour [57.2 h] | 17.44 | 1F4CVL | Arch'l | 4 | MB |
| 1F5-FNS-P06-390 |  | P06 . AREA-4 -Install Ceiling | 10d | 2019-04-28 | 2019-05-06 | 1F5-FNS-P06-350, 1F5-FNS-P06-370, 1F5-FNS-P06-380 | 197.5d | 0d | Unskilled Labour [171.6 h]; Skilled Labour [228.8 h] | 30.52 | 1F4CVL | Arch'l | 4 | MB |
| 1F5-FNS-P06-400 |  | P06 . AREA-4 -Install Floor Tiles | 7.5d | 2019-05-07 | 2019-05-13 | 1F5-FNS-P06-390 | 232.25d | 32.75d | Skilled Labour [257.4 h]; Unskilled Labour [128.7 h] | 29.43 | 1F4CVL | Arch'l | 4 | MB |
| 1F5-FNS-P06-410 |  | P06 . AREA-4 -Ceiling Final Painting | 7.5d | 2019-06-17 | 2019-06-24 | MR300, 1F5-FNS-P06-380, 1F5-FNS-P06-350, 1F5-FNS-P06-400 | 199.5d | 0d | Skilled Labour [214.5 h]; Unskilled Labour [128.7 h] | 26.16 | 1F4CVL | Arch'l | 4 | MB |
| 1F5-FNS-P06-420 |  | P06 . AREA-4 -Walls Final Painting | 7.5d | 2019-06-17 | 2019-06-24 | MR300, 1F5-FNS-P06-290, 1F5-FNS-P06-390 | 157.25d | 0d | Unskilled Labour [128.7 h]; Skilled Labour [214.5 h] | 26.16 | 1F4CVL | Arch'l | 4 | MB |
| 1F5-FNS-P06-430 |  | P06 . AREA-4 -Floor Epoxy Painting | 6.25d | 2019-06-24 | 2019-06-30 | 1F5-FNS-P06-420, 1F5-FNS-P06-410, 1F5-FNS-P06-370 | 199.5d | 58.75d | Skilled Labour [143 h]; Unskilled Labour [143 h] | 21.8 | 1F4CVL | Arch'l | 4 | MB |
| 1F5-FNS-P06-440 |  | P06 . AREA-4 -Install Door & Hardware/Accessories | 3.75d | 2019-08-27 | 2019-08-31 | 1F5-FNS-P06-430, 1F5-FNS-P06-220, LOE-SUM2-020 FF | 140.75d | 40d | Skilled Labour [57.2 h]; Unskilled Labour [57.2 h] | 8.72 | 1F4CVL | Arch'l | 4 | MB |
|  | 5 | **P06 . AREA-3** |  | 2019-01-02 | 2019-10-12 |  |  |  |  |  |  |  |  |  |
|  | 3 | **SIEMENS ROOM** |  | 2019-01-02 | 2019-05-27 |  |  |  |  |  |  |  |  |  |
|  | 1 | **Wet Finishes** |  | 2019-01-02 | 2019-05-27 |  |  |  |  |  |  |  |  |  |
| 1F5-FNS-P06-450 |  | P06 . AREA-3 . SR - Block Masonry | 15d | 2019-01-02 | 2019-01-15 | 1F5-FNS-P06-230 | 5.5d | 0d | Unskilled Labour [514.8 h]; Skilled Labour [1029.6 h] | 117.7 | 1F4CVL | Arch'l | 3 | MB |
| 1F5-FNS-P06-460 |  | P06 . AREA-3 . SR - Interior Plaster & Rendering | 10d | 2019-01-13 | 2019-01-21 | 1F5-FNS-P06-450 FF+6.25d | 5.5d | 0d | Skilled Labour [457.6 h]; Unskilled Labour [228.8 h] | 52.31 | 1F4CVL | Arch'l | 3 | MB |
| 1F5-FNS-P06-470 |  | P06 . AREA-3 . SR - Ceiling Painting 1st Coat | 5d | 2019-01-22 | 2019-01-26 | 1F5-FNS-P06-450, 1F5-FNS-P06-460 | 5.5d | 0d | Skilled Labour [171.6 h]; Unskilled Labour [114.4 h] | 21.8 | 1F4CVL | Arch'l | 3 | MB |
| 1F5-FNS-P06-480 |  | P06 . AREA-3 . SR - Walls Painting 1st Coat | 5d | 2019-01-27 | 2019-01-30 | 1F5-FNS-P06-470 | 5.5d | 0d | Skilled Labour [228.8 h]; Unskilled Labour [171.6 h] | 30.52 | 1F4CVL | Arch'l | 3 | MB |
| 1F5-FNS-P06-490 |  | P06 . AREA-3 . SR - Floor Concreted Screeding | 10d | 2019-01-31 | 2019-02-09 | 1F5-FNS-P06-480, 1F5-FNS-P06-480 SS | 5.5d | 0d | Unskilled Labour [343.2 h]; Skilled Labour [686.4 h] | 78.47 | 1F4CVL | Arch'l | 3 | MB |

| ID | WBS | Activity | Duration | Start | Finish | Predecessors | Total float | Free float | Resources | Cost | 1F4 PROJECT | Discipline | AREA | LOCATION |
| --- | --- | --- | --- | --- | --- | --- | --- | --- | --- | --- | --- | --- | --- | --- |
|  | 2 | **Final finishes prior to Handing over to Siemens** |  | 2019-05-06 | 2019-05-27 |  |  |  |  |  |  |  |  |  |
| 1F5-FNS-P06-500 |  | P06 . AREA-3 . SR - Ceiling Final Painting | 6.25d | 2019-05-06 | 2019-05-12 | 1F5-FNS-P06-470, MR325, 1F5-FNS-P06-490 | 5.5d | 0d | Skilled Labour [171.6 h]; Unskilled Labour [171.6 h] | 26.16 | 1F4CVL | Arch'l | 3 | MB |
| 1F5-FNS-P06-510 |  | P06 . AREA-3 . SR - Walls Final Painting | 6.25d | 2019-05-12 | 2019-05-18 | 1F5-FNS-P06-500, 1F5-FNS-P06-470 FS+47.5d, 1F5-FNS-P06-490 FF+2.5d | 5.5d | 0d | Unskilled Labour [171.6 h]; Skilled Labour [171.6 h] | 26.16 | 1F4CVL | Arch'l | 3 | MB |
| 1F5-FNS-P06-520 |  | P06 . AREA-3 . SR - Floor Final finishes | 6.25d | 2019-05-18 | 2019-05-23 | 1F5-FNS-P06-510, 1F5-FNS-P06-490, 1F5-FNS-P06-500 | 30.5d | 0d | Skilled Labour [171.6 h]; Unskilled Labour [114.4 h] | 21.8 | 1F4CVL | Arch'l | 3 | MB |
| 1F5-FNS-P06-530 |  | P06 . AREA-3 . SR -Install Door Hardware/Accessories | 3.75d | 2019-05-23 | 2019-05-27 | 1F5-FNS-P06-305, 1F5-FNS-P06-520 FF, 1F5-FNS-P06-300, 1F5-FNS-P06-520, LOE-SUM2-040 FF | 30.5d | 7d | Skilled Labour [85.8 h]; Unskilled Labour [57.2 h] | 10.9 | 1F4CVL | Arch'l | 3 | MB |
|  | 4 | **BOH / FOH (incl under Platform)** |  | 2019-04-22 | 2019-10-12 |  |  |  |  |  |  |  |  |  |
| 1F5-FNS-P06-540 |  | P06 . AREA-3 -Block Masonry | 15d | 2019-04-22 | 2019-05-05 | 1F5-FNS-P06-460, 1F5-FNS-P06-370, 1F5-FNS-P06-450, C1C1111F5C1150 | 62.25d | 0d | Unskilled Labour [429 h]; Skilled Labour [686.4 h] | 85 | 1F4CVL | Arch'l | 3 | MB |
| 1F5-FNS-P06-550 |  | P06 . AREA-3 -Interior Plaster & Rendering | 12.5d | 2019-04-28 | 2019-05-08 | 1F5-FNS-P06-540 FF+3.75d | 62.25d | 0d | Skilled Labour [429 h]; Unskilled Labour [257.4 h] | 52.31 | 1F4CVL | Arch'l | 3 | MB |
| 1F5-FNS-P06-560 |  | P06 . AREA-3 -Gypsum Partition and Panel | 7.5d | 2019-05-09 | 2019-05-15 | 1F5-FNS-P06-550 | 62.25d | 0d | Skilled Labour [257.4 h]; Unskilled Labour [85.8 h] | 26.16 |  | Arch'l | 3 | MB |
| 1F5-FNS-P06-570 |  | P06 . AREA-3 -Ceiling Painting 1st Coat | 6.25d | 2019-05-16 | 2019-05-21 | 1F5-FNS-P06-540, 1F5-FNS-P06-560 | 62.25d | 0d | Skilled Labour [178.75 h]; Unskilled Labour [143 h] | 24.52 | 1F4CVL | Arch'l | 3 | MB |
| 1F5-FNS-P06-580 |  | P06 . AREA-3 -Walls Painting 1st Coat | 7.5d | 2019-05-22 | 2019-05-28 | 1F5-FNS-P06-550 FS+2.5d, 1F5-FNS-P06-570 | 62.25d | 0d | Skilled Labour [214.5 h]; Unskilled Labour [214.5 h] | 32.7 | 1F4CVL | Arch'l | 3 | MB |
| 1F5-FNS-P06-590 |  | P06 . AREA-3 -Floor Concreted Screeding | 7.5d | 2019-05-29 | 2019-06-08 | 1F5-FNS-P06-580 | 62.25d | 0d | Unskilled Labour [171.6 h]; Skilled Labour [171.6 h] | 26.16 | 1F4CVL | Arch'l | 3 | MB |
| 1F5-FNS-P06-600 |  | P06 . AREA-3 -Raised Flooring | 6.25d | 2019-06-09 | 2019-06-13 | 1F5-FNS-P06-380, 1F5-FNS-P06-590 | 142.5d | 0d | Skilled Labour [171.6 h]; Unskilled Labour [57.2 h] | 17.44 | 1F4CVL | Arch'l | 3 | MB |
| 1F5-FNS-P06-610 |  | P06 . AREA-3 -Install Ceiling | 10d | 2019-06-15 | 2019-06-23 | 1F5-FNS-P06-590, 1F5-FNS-P06-600 | 142.5d | 0d | Unskilled Labour [171.6 h]; Skilled Labour [228.8 h] | 30.52 | 1F4CVL | Arch'l | 3 | MB |
| 1F5-FNS-P06-620 |  | P06 . AREA-3 -Install Floor Tiles | 7.5d | 2019-06-24 | 2019-06-30 | 1F5-FNS-P06-610 SS+3.75d, 1F5-FNS-P06-610 | 142.5d | 80.25d | Skilled Labour [257.4 h]; Unskilled Labour [128.7 h] | 29.43 | 1F4CVL | Arch'l | 3 | MB |
| 1F5-FNS-P06-630 |  | P06 . AREA-3 -Ceiling Final Painting | 7.5d | 2019-09-17 | 2019-09-25 | MR320, 1F5-FNS-P06-620 | 62.25d | 0d | Skilled Labour [214.5 h]; Unskilled Labour [128.7 h] | 26.16 | 1F4CVL | Arch'l | 3 | MB |
| 1F5-FNS-P06-640 |  | P06 . AREA-3 -Walls Final Painting | 7.5d | 2019-09-25 | 2019-10-02 | 1F5-FNS-P06-630, MR620, 1F5-FNS-P06-610, 1F5-FNS-P06-610 FF, MR320, 1F5-FNS-P06-420, 1F5-FNS-P06-510 | 62.25d | 0d | Unskilled Labour [128.7 h]; Skilled Labour [214.5 h] | 26.16 | 1F4CVL | Arch'l | 3 | MB |
| 1F5-FNS-P06-650 |  | P06 . AREA-3 -Floor Epoxy Painting | 6.25d | 2019-10-02 | 2019-10-08 | 1F5-FNS-P06-640, 1F5-FNS-P06-630 | 100.75d | 0d | Skilled Labour [143 h]; Unskilled Labour [143 h] | 21.8 | 1F4CVL | Arch'l | 3 | MB |
| 1F5-FNS-P06-660 |  | P06 . AREA-3 -Install Door & Hardware/Accessories | 3.75d | 2019-10-08 | 2019-10-12 | 1F5-FNS-P06-650, 1F5-FNS-P06-440, 1F5-FNS-P06-530, LOE-SUM2-050 FF | 100.75d | 0d | Skilled Labour [57.2 h]; Unskilled Labour [57.2 h] | 8.72 | 1F4CVL | Arch'l | 3 | MB |
|  | 4 | **P06 . AREA-2** |  | 2019-01-06 | 2019-10-15 |  |  |  |  |  |  |  |  |  |
|  | 3 | **SIEMENS ROOM** |  | 2019-01-06 | 2019-06-10 |  |  |  |  |  |  |  |  |  |
|  | 1 | **Wet Finishes** |  | 2019-01-06 | 2019-06-10 |  |  |  |  |  |  |  |  |  |
| 1F5-FNS-P06-670 |  | P06 . AREA-2 . SR - Block Masonry | 15d | 2019-01-06 | 2019-01-19 | 1F5-FNS-P06-450 SS+3.75d | 11.75d | 0d | Unskilled Labour [514.8 h]; Skilled Labour [1029.6 h] | 117.7 | 1F4CVL | Arch'l | 2 | MB |
| 1F5-FNS-P06-680 |  | P06 . AREA-2 . SR - Interior Plaster & Rendering | 10d | 2019-01-16 | 2019-01-24 | 1F5-FNS-P06-670 FF+6.25d | 23.5d | 0d | Skilled Labour [457.6 h]; Unskilled Labour [228.8 h] | 52.31 | 1F4CVL | Arch'l | 2 | MB |
| 1F5-FNS-P06-690 |  | P06 . AREA-2 . SR - Ceiling Painting 1st Coat | 5d | 2019-01-26 | 2019-01-29 | 1F5-FNS-P06-680 | 23.5d | 0d | Skilled Labour [171.6 h]; Unskilled Labour [114.4 h] | 21.8 | 1F4CVL | Arch'l | 2 | MB |
| 1F5-FNS-P06-700 |  | P06 . AREA-2 . SR - Walls Painting 1st Coat | 5d | 2019-01-30 | 2019-02-03 | 1F5-FNS-P06-690, 1F5-FNS-P06-680 | 23.5d | 0d | Skilled Labour [228.8 h]; Unskilled Labour [171.6 h] | 30.52 | 1F4CVL | Arch'l | 2 | MB |
| 1F5-FNS-P06-710 |  | P06 . AREA-2 . SR - Floor Concreted Screeding | 10d | 2019-01-30 | 2019-02-07 | 1F5-FNS-P06-700 SS | 23.5d | 0d | Unskilled Labour [343.2 h]; Skilled Labour [686.4 h] | 78.47 | 1F4CVL | Arch'l | 2 | MB |

| ID | WBS | Activity | Duration | Start | Finish | Predecessors | Total float | Free float | Resources | Cost | 1F4 PROJECT | Discipline | AREA | LOCATION |
| --- | --- | --- | --- | --- | --- | --- | --- | --- | --- | --- | --- | --- | --- | --- |
|  | 2 | **Final finishes prior to Handing over to Siemens** |  | 2019-05-16 | 2019-06-10 |  |  |  |  |  |  |  |  |  |
| 1F5-FNS-P06-720 |  | P06 . AREA-2 . SR - Ceiling Final Painting | 6.25d | 2019-05-16 | 2019-05-22 | 1F5-FNS-P06-710, MR335, 1F5-FNS-P06-690 | 23.5d | 0d | Skilled Labour [171.6 h]; Unskilled Labour [171.6 h] | 26.16 | 1F4CVL | Arch'l | 2 | MB |
| 1F5-FNS-P06-730 |  | P06 . AREA-2 . SR - Walls Final Painting | 6.25d | 2019-05-22 | 2019-05-28 | MR335, 1F5-FNS-P06-690 FS+32.5d, 1F5-FNS-P06-720 | 23.5d | 0d | Unskilled Labour [171.6 h]; Skilled Labour [171.6 h] | 26.16 | 1F4CVL | Arch'l | 2 | MB |
| 1F5-FNS-P06-740 |  | P06 . AREA-2 . SR - Floor Final finishes | 6.25d | 2019-05-28 | 2019-06-03 | 1F5-FNS-P06-710, 1F5-FNS-P06-730, 1F5-FNS-P06-720 | 23.5d | 0d | Skilled Labour [171.6 h]; Unskilled Labour [114.4 h] | 21.8 | 1F4CVL | Arch'l | 2 | MB |
| 1F5-FNS-P06-750 |  | P06 . AREA-2 . SR -Install Door Hardware/Accessories | 3.75d | 2019-06-03 | 2019-06-10 | 1F5-FNS-P06-740, 1F5-FNS-P06-530, LOE-SUM2-060 FF | 23.5d | 9.25d | Skilled Labour [85.8 h]; Unskilled Labour [57.2 h] | 10.9 | 1F4CVL | Arch'l | 2 | MB |
|  | 4 | **BOH / FOH (incl under Platform)** |  | 2019-03-20 | 2019-10-15 |  |  |  |  |  |  |  |  |  |
| 1F5-FNS-P06-760 |  | P06 . AREA-2 -Block Masonry | 15d | 2019-03-20 | 2019-04-02 | C1C1111F5N1520 FS+22.5d, 1F5-FNS-P06-3000 FF, 1F5-FNS-P06-670, 1F5-FNS-P06-680 | 102.25d | 0d | Unskilled Labour [429 h]; Skilled Labour [686.4 h] | 85 | 1F4CVL | Arch'l | 2 | MB |
| 1F5-FNS-P06-770 |  | P06 . AREA-2 -Interior Plaster & Rendering | 12.5d | 2019-03-28 | 2019-04-08 | 1F5-FNS-P06-3010 FF, 1F5-FNS-P06-680, 1F5-FNS-P06-760 FF+6.25d | 102.25d | 0d | Skilled Labour [429 h]; Unskilled Labour [257.4 h] | 52.31 | 1F4CVL | Arch'l | 2 | MB |
| 1F5-FNS-P06-780 |  | P06 . AREA-2 -Gypsum Partition and Panel | 7.5d | 2019-04-09 | 2019-04-15 | 1F5-FNS-P06-770 | 102.25d | 0d | Skilled Labour [257.4 h]; Unskilled Labour [85.8 h] | 26.16 |  | Arch'l | 2 | MB |
| 1F5-FNS-P06-790 |  | P06 . AREA-2 -Ceiling Painting 1st Coat | 6.25d | 2019-04-16 | 2019-04-21 | 1F5-FNS-P06-780, 1F5-FNS-P06-760 | 102.25d | 0d | Skilled Labour [178.75 h]; Unskilled Labour [143 h] | 24.52 | 1F4CVL | Arch'l | 2 | MB |
| 1F5-FNS-P06-800 |  | P06 . AREA-2 -Walls Painting 1st Coat | 7.5d | 2019-04-22 | 2019-04-28 | 1F5-FNS-P06-770 FS+2.5d, 1F5-FNS-P06-790 | 102.25d | 0d | Skilled Labour [214.5 h]; Unskilled Labour [214.5 h] | 32.7 | 1F4CVL | Arch'l | 2 | MB |
| 1F5-FNS-P06-810 |  | P06 . AREA-2 -Floor Concreted Screeding | 7.5d | 2019-04-29 | 2019-05-05 | 1F5-FNS-P06-800 | 102.25d | 0d | Unskilled Labour [171.6 h]; Skilled Labour [171.6 h] | 26.16 | 1F4CVL | Arch'l | 2 | MB |
| 1F5-FNS-P06-830 |  | P06 . AREA-2 -Install Ceiling | 10d | 2019-05-06 | 2019-05-14 | 1F5-FNS-P06-810, 1F5-FNS-P06-790 | 188.75d | 0d | Unskilled Labour [171.6 h]; Skilled Labour [228.8 h] | 30.52 | 1F4CVL | Arch'l | 2 | MB |
| 1F5-FNS-P06-840 |  | P06 . AREA-2 -Install Floor Tiles | 7.5d | 2019-05-15 | 2019-05-21 | 1F5-FNS-P06-830 | 188.75d | 89d | Skilled Labour [257.4 h]; Unskilled Labour [128.7 h] | 29.43 | 1F4CVL | Arch'l | 2 | MB |
| 1F5-FNS-P06-820 |  | P06 . AREA-2 -Raised Flooring | 6.25d | 2019-06-15 | 2019-06-19 | 1F5-FNS-P06-810, 1F5-FNS-P06-600 | 161.25d | 61.5d | Skilled Labour [171.6 h]; Unskilled Labour [57.2 h] | 17.44 | 1F4CVL | Arch'l | 2 | MB |
| 1F5-FNS-P06-850 |  | P06 . AREA-2 -Ceiling Final Painting | 7.5d | 2019-08-20 | 2019-08-27 | 1F5-FNS-P06-790, MR330, 1F5-FNS-P06-840, 1F5-FNS-P06-820 | 99.75d | 0d | Skilled Labour [214.5 h]; Unskilled Labour [128.7 h] | 26.16 | 1F4CVL | Arch'l | 2 | MB |
| 1F5-FNS-P06-860 |  | P06 . AREA-2 -Walls Final Painting | 7.5d | 2019-10-02 | 2019-10-09 | 1F5-FNS-P06-640, 1F5-FNS-P06-830, 1F5-FNS-P06-850, MR330, 1F5-FNS-P06-730, MR630 | 62.25d | 0d | Unskilled Labour [128.7 h]; Skilled Labour [214.5 h] | 26.16 | 1F4CVL | Arch'l | 2 | MB |
| 1F5-FNS-P06-890 |  | P06 . AREA-2 -Floor Epoxy Painting | 6.25d | 2019-10-09 | 2019-10-15 | 1F5-FNS-P06-810, 1F5-FNS-P06-860, 1F5-FNS-P06-3080 FF, 1F5-FNS-P06-850 | 100.75d | 0d | Skilled Labour [143 h]; Unskilled Labour [143 h] | 21.8 | 1F4CVL | Arch'l | 2 | MB |
| 1F5-FNS-P06-900 |  | P06 . AREA-2 -Install Door & Hardware/Accessories | 3.75d | 2019-10-12 | 2019-10-15 | 1F5-FNS-P06-660, 1F5-FNS-P06-750, 1F5-FNS-P06-890 FF, 1F5-FNS-P06-840 FF, LOE-SUM2-070 FF | 100.75d | 7.5d | Skilled Labour [57.2 h]; Unskilled Labour [57.2 h] | 8.72 | 1F4CVL | Arch'l | 2 | MB |
|  | 3 | **P06 . AREA-1** |  | 2019-01-09 | 2019-10-26 |  |  |  |  |  |  |  |  |  |
|  | 3 | **SIEMENS ROOMs** |  | 2019-01-09 | 2019-06-23 |  |  |  |  |  |  |  |  |  |
|  | 1 | **Wet Finishes** |  | 2019-01-09 | 2019-06-23 |  |  |  |  |  |  |  |  |  |
| 1F5-FNS-P06-910 |  | P06 . AREA-1 . SR - Block Masonry | 15d | 2019-01-09 | 2019-01-22 | 1F5-FNS-P06-670 SS+3.75d | 11.75d | 0d | Unskilled Labour [514.8 h]; Skilled Labour [1029.6 h] | 117.7 | 1F4CVL | Arch'l | 1 | MB |
| 1F5-FNS-P06-920 |  | P06 . AREA-1 . SR - Interior Plaster & Rendering | 10d | 2019-01-20 | 2019-01-28 | 1F5-FNS-P06-910 FF+6.25d | 11.75d | 0d | Skilled Labour [457.6 h]; Unskilled Labour [228.8 h] | 52.31 | 1F4CVL | Arch'l | 1 | MB |
| 1F5-FNS-P06-930 |  | P06 . AREA-1 . SR - Ceiling Painting 1st Coat | 5d | 2019-01-29 | 2019-02-02 | 1F5-FNS-P06-910, 1F5-FNS-P06-920 | 11.75d | 0d | Skilled Labour [171.6 h]; Unskilled Labour [114.4 h] | 21.8 | 1F4CVL | Arch'l | 1 | MB |
| 1F5-FNS-P06-940 |  | P06 . AREA-1 . SR - Walls Painting 1st Coat | 5d | 2019-02-03 | 2019-02-06 | 1F5-FNS-P06-920, 1F5-FNS-P06-930 | 11.75d | 0d | Skilled Labour [228.8 h]; Unskilled Labour [171.6 h] | 30.52 | 1F4CVL | Arch'l | 1 | MB |
| 1F5-FNS-P06-950 |  | P06 . AREA-1 . SR - Floor Concreted Screeding | 10d | 2019-02-03 | 2019-02-11 | 1F5-FNS-P06-940 SS | 11.75d | 0d | Unskilled Labour [343.2 h]; Skilled Labour [686.4 h] | 78.47 | 1F4CVL | Arch'l | 1 | MB |

| ID | WBS | Activity | Type | Duration | Start | Finish | Predecessors | Total float | Free float | Resources | Cost | 1F4 PROJECT | Discipline | AREA | LOCATION |
| --- | --- | --- | --- | --- | --- | --- | --- | --- | --- | --- | --- | --- | --- | --- | --- |
|  | 2 | **Final finishes prior to Handing over to Siemens** |  |  | 2019-05-25 | 2019-06-23 |  |  |  |  |  |  |  |  |  |
| 1F5-FNS-P06-960 |  | P06 . AREA-1 . SR - Ceiling Final Painting |  | 7.5d | 2019-05-25 | 2019-06-01 | 1F5-FNS-P06-930, MR345, 1F5-FNS-P06-950 | 14.25d | 0d | Skilled Labour [171.6 h]; Unskilled Labour [171.6 h] | 26.16 | 1F4CVL | Arch'l | 1 | MB |
| 1F5-FNS-P06-970 |  | P06 . AREA-1 . SR - Walls Final Painting |  | 7.5d | 2019-06-01 | 2019-06-11 | 1F5-FNS-P06-930, 1F5-FNS-P06-960, 1F5-FNS-P06-950 | 14.25d | 0d | Unskilled Labour [171.6 h]; Skilled Labour [171.6 h] | 26.16 | 1F4CVL | Arch'l | 1 | MB |
| 1F5-FNS-P06-980 |  | P06 . AREA-1 . SR - Floor Final finishes |  | 7.5d | 2019-06-11 | 2019-06-18 | 1F5-FNS-P06-970, 1F5-FNS-P06-960 | 14.25d | 0d | Skilled Labour [171.6 h]; Unskilled Labour [114.4 h] | 21.8 | 1F4CVL | Arch'l | 1 | MB |
| 1F5-FNS-P06-990 |  | P06 . AREA-1 . SR -Install Door Hardware/Accessories |  | 5d | 2019-06-18 | 2019-06-23 | 1F5-FNS-P06-980, 1F5-FNS-P06-750, LOE-SUM2-060 FF | 14.25d | 2.5d | Skilled Labour [85.8 h]; Unskilled Labour [57.2 h] | 10.9 | 1F4CVL | Arch'l | 1 | MB |
|  | 4 | **BOH / FOH (incl under Platform)** |  |  | 2019-03-25 | 2019-10-26 |  |  |  |  |  |  |  |  |  |
| 1F5-FNS-P06-1000 |  | P06 . AREA-1 -Block Masonry |  | 15d | 2019-03-25 | 2019-04-07 | 1F5-FNS-P06-3000 FF, C1C1111F5N1620 FS+22.5d, 1F5-FNS-P06-910 | 99.75d | 0d | Unskilled Labour [429 h]; Skilled Labour [686.4 h] | 85 | 1F4CVL | Arch'l | 1 | MB |
| 1F5-FNS-P06-1010 |  | P06 . AREA-1 -Interior Plaster & Rendering |  | 12.5d | 2019-03-31 | 2019-04-10 | 1F5-FNS-P06-3010 FF, 1F5-FNS-P06-1000 FF+3.75d | 99.75d | 0d | Skilled Labour [429 h]; Unskilled Labour [257.4 h] | 52.31 | 1F4CVL | Arch'l | 1 | MB |
| 1F5-FNS-P06-1020 |  | P06 . AREA-1 -Gypsum Partition and Panel |  | 7.5d | 2019-04-11 | 2019-04-17 | 1F5-FNS-P06-1010 | 99.75d | 0d | Skilled Labour [257.4 h]; Unskilled Labour [85.8 h] | 26.16 |  | Arch'l | 1 | MB |
| 1F5-FNS-P06-1030 |  | P06 . AREA-1 -Ceiling Painting 1st Coat |  | 6.25d | 2019-04-18 | 2019-04-23 | 1F5-FNS-P06-1000, 1F5-FNS-P06-1020 | 99.75d | 0d | Skilled Labour [178.75 h]; Unskilled Labour [143 h] | 24.52 | 1F4CVL | Arch'l | 1 | MB |
| 1F5-FNS-P06-1040 |  | P06 . AREA-1 -Walls Painting 1st Coat |  | 7.5d | 2019-04-24 | 2019-04-30 | 1F5-FNS-P06-1030, 1F5-FNS-P06-3020 FF, 1F5-ARDWG610 | 99.75d | 0d | Skilled Labour [214.5 h]; Unskilled Labour [214.5 h] | 32.7 | 1F4CVL | Arch'l | 1 | MB |
| 1F5-FNS-P06-1050 |  | P06 . AREA-1 -Floor Concreted Screeding |  | 7.5d | 2019-05-01 | 2019-05-07 | 1F5-FNS-P06-3030 FF, 1F5-FNS-P06-1040 | 99.75d | 0d | Skilled Labour [171.6 h]; Unskilled Labour [171.6 h] | 26.16 | 1F4CVL | Arch'l | 1 | MB |
| 1F5-FNS-P06-1060 |  | P06 . AREA-1 -Raised Flooring |  | 6.25d | 2019-05-08 | 2019-05-13 | 1F5-FNS-P06-1050 | 218.5d | 0d | Skilled Labour [171.6 h]; Unskilled Labour [57.2 h] | 17.44 | 1F4CVL | Arch'l | 1 | MB |
| 1F5-FNS-P06-1070 |  | P06 . AREA-1 -Install Ceiling |  | 10d | 2019-05-14 | 2019-05-22 | 1F5-FNS-P06-1060, 1F5-FNS-P06-1050 | 218.5d | 0d | Unskilled Labour [171.6 h]; Skilled Labour [228.8 h] | 30.52 | 1F4CVL | Arch'l | 1 | MB |
| 1F5-FNS-P06-1080 |  | P06 . AREA-1 -Install Floor Tiles |  | 7.5d | 2019-05-23 | 2019-05-29 | 1F5-FNS-P06-1070 | 218.5d | 80.25d | Skilled Labour [257.4 h]; Unskilled Labour [128.7 h] | 29.43 | 1F4CVL | Arch'l | 1 | MB |
| 1F5-FNS-P06-1090 |  | P06 . AREA-1 -Ceiling Final Painting |  | 7.5d | 2019-08-20 | 2019-08-27 | MR340, 1F5-FNS-P06-1080 | 138.25d | 45d | Skilled Labour [214.5 h]; Unskilled Labour [128.7 h] | 26.16 | 1F4CVL | Arch'l | 1 | MB |
| 1F5-FNS-P06-1100 |  | P06 . AREA-1 -Walls Final Painting |  | 7.5d | 2019-10-09 | 2019-10-16 | MR340, MR345, 1F5-FNS-P06-1090, 1F5-FNS-P06-860, 1F5-FNS-P06-970, MR640 | 93.25d | 0d | Unskilled Labour [128.7 h]; Skilled Labour [214.5 h] | 26.16 | 1F4CVL | Arch'l | 1 | MB |
| 1F5-FNS-P06-1110 |  | P06 . AREA-1 -Floor Epoxy Painting |  | 6.25d | 2019-10-16 | 2019-10-22 | 1F5-FNS-P06-3080 FF, 1F5-FNS-P06-1100 FF, 1F5-FNS-P06-1100 | 93.25d | 0d | Skilled Labour [143 h]; Unskilled Labour [143 h] | 21.8 | 1F4CVL | Arch'l | 1 | MB |
| 1F5-FNS-P06-1120 |  | P06 . AREA-1 -Install Door & Hardware/Accessories |  | 3.75d | 2019-10-22 | 2019-10-26 | 1F5-FNS-P06-990, 1F5-FNS-P06-1110, 1F5-FNS-P06-900, LOE-SUM2-070 FF | 93.25d | 89.5d | Skilled Labour [57.2 h]; Unskilled Labour [57.2 h] | 8.72 | 1F4CVL | Arch'l | 1 | MB |
|  | 11 | **LOE Commodities ARCHL - P06 . Main Box . AREA-5 to AREA-1** |  |  | 2018-12-16 | 2019-10-22 |  |  |  |  |  |  |  |  |  |
| 1F5-FNS-P06-3000 |  | LOE Archl - P06 . Main Box . AREA-5 to AREA-1 - Blockworks | level of effort | 121.25d | 2018-12-16 | 2019-04-07 | 1F5-FNS-P06-010 SS | 99.75d | 0d | Block Work [2364.39 Square Meter] |  |  | Arch'l | 5 | MB |
| 1F5-FNS-P06-3010 |  | LOE Archl - P06 . Main Box . AREA-5 to AREA-1 - Plastering | level of effort | 112.5d | 2018-12-27 | 2019-04-10 | 1F5-FNS-P06-020 SS, 1F5-FNS-P06-240 SS | 99.75d | 0d | Plaster Work [5261 Square Meter] |  |  | Arch'l | 5 | MB |
| 1F5-FNS-P06-3020 |  | LOE Archl - P06 . Main Box . AREA-5 to AREA-1 - Initial Painting | level of effort | 123.75d | 2019-01-06 | 2019-04-30 | 1F5-FNS-P06-030 SS, 1F5-FNS-P06-250 SS | 99.75d | 0d | Painting [3913 Square Meter] |  |  | Arch'l | 5 | MB |
| 1F5-FNS-P06-3030 |  | LOE Archl - P06 . Main Box . AREA-5 to AREA-1 - Screed | level of effort | 121.25d | 2019-01-15 | 2019-05-07 | 1F5-FNS-P06-050 SS | 99.75d | 0d | Screed Work [1825 Square Meter] |  |  | Arch'l | 5 | MB |
| 1F5-FNS-P06-3080 |  | LOE Archl - P06 . Main Box . AREA-5 to AREA-1 - Final Painting | level of effort | 177.5d | 2019-05-01 | 2019-10-22 | 1F5-FNS-P06-060A SS | 93.25d | 0d | Painting [1304 Square Meter] |  |  | Arch'l | 5 | MB |

| ID | WBS | Activity | Type | Duration | Start | Finish | Predecessors | Total float | Free float | Calendar | Resources | Cost | Discipline | 1F4 PROJECT | AREA | LOCATION |
| --- | --- | --- | --- | --- | --- | --- | --- | --- | --- | --- | --- | --- | --- | --- | --- | --- |
|  | 2 | **MEZZANINE LEVEL (B05)** |  |  | 2019-01-16 | 2019-11-20 |  |  |  |  |  |  |  |  |  |  |
| LOE-SUM2-080 |  | South . B05 . BOH / FOH - Archl Works | level of effort | 204d | 2019-01-16 | 2019-07-25 | 1F5-FNS-B05-870 SS | 181d | 0d | Saudi |  |  | Arch'l |  |  |  |
| LOE-SUM2-090 |  | Central . B05 . BOH / FOH - Archl Works | level of effort | 167.75d | 2019-04-07 | 2019-09-10 | 1F5-FNS-B05-1130 | 131d | 0d | Saudi |  |  | Arch'l |  |  |  |
| LOE-SUM2-100 |  | North . B05 . BOH / FOH - Archl Works | level of effort | 209.25d | 2019-05-09 | 2019-11-20 | 1F5-FNS-B05-1260 SS | 65.75d | 0d | Saudi |  |  | Arch'l |  |  |  |
|  | 2 | **B05 . AREA-5** |  |  | 2019-01-16 | 2019-07-06 |  |  |  |  |  |  |  |  |  |  |
|  | 4 | **BOH / FOH** |  |  | 2019-01-16 | 2019-07-06 |  |  |  |  |  |  |  |  |  |  |
| 1F5-FNS-B05-870 |  | B05 . AREA-5 -Block Masonry |  | 15d | 2019-01-16 | 2019-01-29 | 1F5-ARDWG630, 1F5-FNS-P06-450 | 27.25d | 0d |  | Unskilled Labour [429 h]; Skilled Labour [686.4 h] | 85 | Arch'l | 1F4CVL | 5 | MB |
| 1F5-FNS-B05-880 |  | B05 . AREA-5 -Interior Plaster & Rendering |  | 12.5d | 2019-01-24 | 2019-02-04 | 1F5-ARDWG640, 1F5-FNS-B05-870 FF+6.25d | 27.25d | 0d |  | Skilled Labour [429 h]; Unskilled Labour [257.4 h] | 52.31 | Arch'l | 1F4CVL | 5 | MB |
| 1F5-FNS-B05-885 |  | B05 . AREA-5 -Gypsum Partition and Panel |  | 7.5d | 2019-02-05 | 2019-02-11 | 1F5-ARDWG670, 1F5-FNS-B05-880 | 139.75d | 0d |  | Skilled Labour [257.4 h]; Unskilled Labour [85.8 h] | 26.16 | Arch'l |  | 5 | MB |
| 1F5-FNS-B05-890 |  | B05 . AREA-5 -Ceiling Painting 1st Coat |  | 6.25d | 2019-02-12 | 2019-02-17 | 1F5-ARDWG650, 1F5-FNS-B05-870, 1F5-FNS-B05-885 | 139.75d | 0d |  | Skilled Labour [178.75 h]; Unskilled Labour [143 h] | 24.52 | Arch'l | 1F4CVL | 5 | MB |
| 1F5-FNS-B05-900 |  | B05 . AREA-5 -Walls Painting 1st Coat |  | 7.5d | 2019-02-18 | 2019-02-24 | 1F5-ARDWG680, 1F5-FNS-B05-880 FS+2.5d, 1F5-FNS-B05-890 | 139.75d | 0d |  | Skilled Labour [214.5 h]; Unskilled Labour [214.5 h] | 32.7 | Arch'l | 1F4CVL | 5 | MB |
| 1F5-FNS-B05-910 |  | B05 . AREA-5 -Floor Concreted Screeding |  | 7.5d | 2019-02-25 | 2019-03-03 | 1F5-FNS-B05-900 | 139.75d | 0d |  | Unskilled Labour [171.6 h]; Skilled Labour [171.6 h] | 26.16 | Arch'l | 1F4CVL | 5 | MB |
| 1F5-FNS-B05-920 |  | B05 . AREA-5 -Raised Flooring |  | 6.25d | 2019-03-04 | 2019-03-09 | 1F5-ARDWG660, 1F5-FNS-B05-910 | 220d | 0d |  | Skilled Labour [171.6 h]; Unskilled Labour [57.2 h] | 17.44 | Arch'l | 1F4CVL | 5 | MB |
| 1F5-FNS-B05-930 |  | B05 . AREA-5 -Install Ceiling |  | 10d | 2019-03-10 | 2019-03-18 | 1F5-FNS-B05-920, 1F5-FNS-B05-890 | 220d | 0d |  | Unskilled Labour [171.6 h]; Skilled Labour [228.8 h] | 30.52 | Arch'l | 1F4CVL | 5 | MB |
| 1F5-FNS-B05-940 |  | B05 . AREA-5 -Install Floor Tiles |  | 7.5d | 2019-03-19 | 2019-03-25 | 1F5-FNS-B05-930, 1F5-ARDWG660 | 220d | 80.25d |  | Skilled Labour [257.4 h]; Unskilled Labour [128.7 h] | 29.43 | Arch'l | 1F4CVL | 5 | MB |
| 1F5-FNS-B05-950 |  | B05 . AREA-5 -Ceiling Final Painting |  | 7.5d | 2019-06-12 | 2019-06-19 | 1F5-FNS-B05-940, 1F5-FNS-B05-890, MR360 | 139.75d | 0d |  | Skilled Labour [214.5 h]; Unskilled Labour [128.7 h] | 26.16 | Arch'l | 1F4CVL | 5 | MB |
| 1F5-FNS-B05-960 |  | B05 . AREA-5 -Walls Final Painting |  | 7.5d | 2019-06-19 | 2019-06-26 | MR335, 1F5-FNS-B05-950 | 139.75d | 0d |  | Unskilled Labour [128.7 h]; Skilled Labour [214.5 h] | 26.16 | Arch'l | 1F4CVL | 5 | MB |
| 1F5-FNS-B05-970 |  | B05 . AREA-5 -Floor Epoxy Painting |  | 6.25d | 2019-06-26 | 2019-07-02 | 1F5-FNS-B05-910, 1F5-FNS-B05-960, 1F5-FNS-B05-950 | 193.25d | 0d |  | Skilled Labour [143 h]; Unskilled Labour [143 h] | 21.8 | Arch'l | 1F4CVL | 5 | MB |
| 1F5-FNS-B05-980 |  | B05 . AREA-5 -Install Door Hardware/Accessories |  | 3.75d | 2019-07-02 | 2019-07-06 | 1F5-FNS-B05-970, 1F5-ARDWG690, 1F5-PRO-GN-520, 1F5-FNS-B05-940 FF, 1F5-PRO-GN-510, 1F5-ARDWG690 FF | 193.25d | 17.5d |  | Skilled Labour [57.2 h]; Unskilled Labour [57.2 h] | 8.72 | Arch'l | 1F4CVL | 5 | MB |
|  | 1 | **B05 . AREA-4** |  |  | 2019-02-05 | 2019-07-25 |  |  |  |  |  |  |  |  |  |  |
|  | 4 | **BOH / FOH** |  |  | 2019-02-05 | 2019-07-25 |  |  |  |  |  |  |  |  |  |  |
| 1F5-FNS-B05-1000 |  | B05 . AREA-4 -Block Masonry |  | 15d | 2019-02-05 | 2019-02-18 | 1F5-FNS-B05-870, 1F5-PRO-GN-420 SS, 1F5-FNS-B05-880, CM040 FF | 27.25d | 0d |  | Unskilled Labour [429 h]; Skilled Labour [686.4 h] | 85 | Arch'l | 1F4CVL | 4 | MB |
| 1F5-FNS-B05-1010 |  | B05 . AREA-4 -Interior Plaster & Rendering |  | 12.5d | 2019-02-13 | 2019-02-24 | 1F5-FNS-B05-1000 FF+6.25d | 27.25d | 0d |  | Skilled Labour [429 h]; Unskilled Labour [257.4 h] | 52.31 | Arch'l | 1F4CVL | 4 | MB |
| 1F5-FNS-B05-1020 |  | B05 . AREA-4 -Gypsum Partition and Panel |  | 7.5d | 2019-02-25 | 2019-03-03 | 1F5-FNS-B05-1010 | 27.25d | 0d |  | Skilled Labour [257.4 h]; Unskilled Labour [85.8 h] | 26.16 | Arch'l |  | 4 | MB |
| 1F5-FNS-B05-1030 |  | B05 . AREA-4 -Ceiling Painting 1st Coat |  | 6.25d | 2019-03-04 | 2019-03-09 | 1F5-FNS-B05-1020, 1F5-FNS-B05-1000 | 27.25d | 0d |  | Skilled Labour [178.75 h]; Unskilled Labour [143 h] | 24.52 | Arch'l | 1F4CVL | 4 | MB |
| 1F5-FNS-B05-1040 |  | B05 . AREA-4 -Walls Painting 1st Coat |  | 7.5d | 2019-03-10 | 2019-03-16 | 1F5-FNS-B05-1010, 1F5-FNS-B05-1030 | 27.25d | 0d |  | Skilled Labour [214.5 h]; Unskilled Labour [214.5 h] | 32.7 | Arch'l | 1F4CVL | 4 | MB |
| 1F5-FNS-B05-1050 |  | B05 . AREA-4 -Floor Concreted Screeding |  | 7.5d | 2019-03-17 | 2019-03-23 | 1F5-FNS-B05-1040 | 27.25d | 0d |  | Unskilled Labour [171.6 h]; Skilled Labour [171.6 h] | 26.16 | Arch'l | 1F4CVL | 4 | MB |
| 1F5-FNS-B05-1060 |  | B05 . AREA-4 -Raised Flooring |  | 6.25d | 2019-03-24 | 2019-03-28 | 1F5-FNS-B05-920, 1F5-FNS-B05-1050 | 206.25d | 0d |  | Skilled Labour [171.6 h]; Unskilled Labour [57.2 h] | 17.44 | Arch'l | 1F4CVL | 4 | MB |
| 1F5-FNS-B05-1070 |  | B05 . AREA-4 -Install Ceiling |  | 10d | 2019-03-30 | 2019-04-07 | 1F5-FNS-B05-1050, 1F5-FNS-B05-1060 | 206.25d | 0d |  | Unskilled Labour [171.6 h]; Skilled Labour [228.8 h] | 30.52 | Arch'l | 1F4CVL | 4 | MB |
| 1F5-FNS-B05-1075 |  | B05 . AREA-4 -Install Floor Tiles |  | 7.5d | 2019-04-08 | 2019-04-14 | 1F5-FNS-B05-1070 | 206.25d | 80.25d |  | Skilled Labour [257.4 h]; Unskilled Labour [128.7 h] | 29.43 | Arch'l | 1F4CVL | 4 | MB |
| 1F5-FNS-B05-1080 |  | B05 . AREA-4 -Ceiling Final Painting |  | 7.5d | 2019-07-02 | 2019-07-09 | 1F5-FNS-B05-1075, MR350, CM050 FF | 126d | 0d |  | Skilled Labour [214.5 h]; Unskilled Labour [128.7 h] | 26.16 | Arch'l | 1F4CVL | 4 | MB |
| 1F5-FNS-B05-1090 |  | B05 . AREA-4 -Walls Final Painting |  | 7.5d | 2019-07-09 | 2019-07-16 | MR350, 1F5-FNS-B05-1080, 1F5-FNS-B05-1075, 1F5-FNS-B05-960 | 126d | 0d |  | Unskilled Labour [128.7 h]; Skilled Labour [214.5 h] | 26.16 | Arch'l | 1F4CVL | 4 | MB |
| 1F5-FNS-B05-1100 |  | B05 . AREA-4 -Floor Epoxy Painting |  | 6.25d | 2019-07-16 | 2019-07-22 | 1F5-FNS-B05-1090, 1F5-FNS-B05-1080 | 175.75d | 0d |  | Skilled Labour [143 h]; Unskilled Labour [143 h] | 21.8 | Arch'l | 1F4CVL | 4 | MB |
| 1F5-FNS-B05-1110 |  | B05 . AREA-4 -Install Door & Hardware/Accessories |  | 3.75d | 2019-07-22 | 2019-07-25 | 1F5-FNS-B05-980, 1F5-FNS-B05-1100, LOE-SUM2-080 FF | 175.75d | 46.25d |  | Skilled Labour [57.2 h]; Unskilled Labour [57.2 h] | 8.72 | Arch'l | 1F4CVL | 4 | MB |

| ID | WBS | Activity | Duration | Start | Finish | Predecessors | Total float | Free float | Resources | Cost | 1F4 PROJECT | Discipline | AREA | LOCATION |
| --- | --- | --- | --- | --- | --- | --- | --- | --- | --- | --- | --- | --- | --- | --- |
|  | 5 | **B05 . AREA-3** |  | 2019-03-24 | 2019-09-14 |  |  |  |  |  |  |  |  |  |
|  | 4 | **BOH / FOH** |  | 2019-03-24 | 2019-09-14 |  |  |  |  |  |  |  |  |  |
| 1F5-FNS-B05-1130 |  | B05 . AREA-3 -Block Masonry | 15d | 2019-03-24 | 2019-04-06 | 1F5-PRO-GN-410, 1F5-FNS-B05-1010, 1F5-FNS-B05-1050, 1F5-FNS-B05-1000 | 27.25d | 0d | Unskilled Labour [429 h]; Skilled Labour [686.4 h] | 85 | 1F4CVL | Arch'l | 3 | MB |
| 1F5-FNS-B05-1140 |  | B05 . AREA-3 -Interior Plaster & Rendering | 12.5d | 2019-04-01 | 2019-04-11 | 1F5-FNS-B05-1010, 1F5-FNS-B05-1130 FF+6.25d | 27.25d | 0d | Skilled Labour [429 h]; Unskilled Labour [257.4 h] | 52.31 | 1F4CVL | Arch'l | 3 | MB |
| 1F5-FNS-B05-1145 |  | B05 . AREA-3 -Gypsum Partition and Panel | 7.5d | 2019-04-13 | 2019-04-18 | 1F5-FNS-B05-1140 | 27.25d | 0d | Skilled Labour [257.4 h]; Unskilled Labour [85.8 h] | 26.16 |  | Arch'l | 3 | MB |
| 1F5-FNS-B05-1150 |  | B05 . AREA-3 -Ceiling Painting 1st Coat | 6.25d | 2019-04-20 | 2019-04-24 | 1F5-FNS-B05-1145, 1F5-FNS-B05-1130, 1F5-FNS-B05-1145 SS | 27.25d | 0d | Skilled Labour [178.75 h]; Unskilled Labour [143 h] | 24.52 | 1F4CVL | Arch'l | 3 | MB |
| 1F5-FNS-B05-1160 |  | B05 . AREA-3 -Walls Painting 1st Coat | 7.5d | 2019-04-25 | 2019-05-01 | 1F5-FNS-B05-1140 FS+2.5d, 1F5-FNS-B05-1150 | 27.25d | 0d | Skilled Labour [214.5 h]; Unskilled Labour [214.5 h] | 32.7 | 1F4CVL | Arch'l | 3 | MB |
| 1F5-FNS-B05-1170 |  | B05 . AREA-3 -Floor Concreted Screeding | 7.5d | 2019-05-02 | 2019-05-08 | 1F5-FNS-B05-1160, 1F5-FNS-B05-1160 SS+2.5d | 27.25d | 0d | Unskilled Labour [171.6 h]; Skilled Labour [171.6 h] | 26.16 | 1F4CVL | Arch'l | 3 | MB |
| 1F5-FNS-B05-1190 |  | B05 . AREA-3 -Raised Flooring | 6.25d | 2019-05-09 | 2019-05-14 | 1F5-FNS-B05-1060, 1F5-FNS-B05-1150, 1F5-FNS-B05-1170 | 163.75d | 0d | Skilled Labour [171.6 h]; Unskilled Labour [57.2 h] | 17.44 | 1F4CVL | Arch'l | 3 | MB |
| 1F5-FNS-B05-1200 |  | B05 . AREA-3 -Install Ceiling | 10d | 2019-05-15 | 2019-05-23 | 1F5-FNS-B05-1190, 1F5-FNS-B05-1150, 1F5-FNS-B05-1170 | 163.75d | 0d | Unskilled Labour [171.6 h]; Skilled Labour [228.8 h] | 30.52 | 1F4CVL | Arch'l | 3 | MB |
| 1F5-FNS-B05-1210 |  | B05 . AREA-3 -Install Floor Tiles | 7.5d | 2019-05-25 | 2019-05-30 | 1F5-FNS-B05-1200 | 163.75d | 80.25d | Skilled Labour [257.4 h]; Unskilled Labour [128.7 h] | 29.43 | 1F4CVL | Arch'l | 3 | MB |
| 1F5-FNS-B05-1220 |  | B05 . AREA-3 -Ceiling Final Painting | 7.5d | 2019-08-21 | 2019-08-28 | 1F5-FNS-B05-1150, MR370, 1F5-FNS-B05-1210 | 83.5d | 0d | Skilled Labour [214.5 h]; Unskilled Labour [128.7 h] | 26.16 | 1F4CVL | Arch'l | 3 | MB |
| 1F5-FNS-B05-1225 |  | B05 . AREA-3 -Walls Final Painting | 7.5d | 2019-08-28 | 2019-09-04 | 1F5-FNS-B05-1090, 1F5-FNS-B05-1220 | 83.5d | 0d | Unskilled Labour [128.7 h]; Skilled Labour [214.5 h] | 26.16 | 1F4CVL | Arch'l | 3 | MB |
| 1F5-FNS-B05-1230 |  | B05 . AREA-3 -Floor Epoxy Painting | 6.25d | 2019-09-04 | 2019-09-10 | 1F5-FNS-B05-1220, 1F5-FNS-B05-1170, 1F5-FNS-B05-1225 | 129.5d | 0d | Skilled Labour [143 h]; Unskilled Labour [143 h] | 21.8 | 1F4CVL | Arch'l | 3 | MB |
| 1F5-FNS-B05-1240 |  | B05 . AREA-3 -Install Door & Hardware/Accessories | 3.75d | 2019-09-10 | 2019-09-14 | 1F5-FNS-B05-1110, 1F5-FNS-B05-1210 FF, 1F5-FNS-B05-1230, LOE-SUM2-090 | 129.5d | 48.75d | Skilled Labour [57.2 h]; Unskilled Labour [57.2 h] | 8.72 | 1F4CVL | Arch'l | 3 | MB |
|  | 4 | **B05 . AREA-2** |  | 2019-05-09 | 2019-11-03 |  |  |  |  |  |  |  |  |  |
|  | 4 | **BOH / FOH** |  | 2019-05-09 | 2019-11-03 |  |  |  |  |  |  |  |  |  |
| 1F5-FNS-B05-1260 |  | B05 . AREA-2 -Block Masonry | 15d | 2019-05-09 | 2019-05-22 | 1F5-FNS-B05-1130, 1F5-FNS-B05-1140, 1F5-FNS-B05-1170 | 27.25d | 0d | Unskilled Labour [429 h]; Skilled Labour [686.4 h] | 85 | 1F4CVL | Arch'l | 2 | MB |
| 1F5-FNS-B05-1270 |  | B05 . AREA-2 -Interior Plaster & Rendering | 12.5d | 2019-05-18 | 2019-05-28 | 1F5-FNS-B05-1260 FF+6.25d | 27.25d | 0d | Skilled Labour [429 h]; Unskilled Labour [257.4 h] | 52.31 | 1F4CVL | Arch'l | 2 | MB |
| 1F5-FNS-B05-1280 |  | B05 . AREA-2 -Walls Painting 1st Coat | 7.5d | 2019-06-01 | 2019-06-10 | 1F5-FNS-B05-1270 FS+2.5d | 38.5d | 0d | Skilled Labour [214.5 h]; Unskilled Labour [214.5 h] | 32.7 | 1F4CVL | Arch'l | 2 | MB |
| 1F5-FNS-B05-1290 |  | B05 . AREA-2 -Gypsum Partition and Panel | 7.5d | 2019-06-11 | 2019-06-17 | 1F5-FNS-B05-1280, 1F5-FNS-B05-1270 | 38.5d | 0d | Skilled Labour [257.4 h]; Unskilled Labour [85.8 h] | 26.16 |  | Arch'l | 2 | MB |
| 1F5-FNS-B05-1300 |  | B05 . AREA-2 -Ceiling Painting 1st Coat | 6.25d | 2019-06-18 | 2019-06-23 | 1F5-FNS-B05-1290, 1F5-FNS-B05-1290 SS, 1F5-FNS-B05-1260 | 38.5d | 0d | Skilled Labour [178.75 h]; Unskilled Labour [143 h] | 24.52 | 1F4CVL | Arch'l | 2 | MB |
| 1F5-FNS-B05-1310 |  | B05 . AREA-2 -Floor Concreted Screeding | 7.5d | 2019-06-24 | 2019-06-30 | 1F5-FNS-B05-1300, 1F5-FNS-B05-1280, 1F5-FNS-B05-1280 SS+2.5d | 38.5d | 0d | Unskilled Labour [171.6 h]; Skilled Labour [171.6 h] | 26.16 | 1F4CVL | Arch'l | 2 | MB |
| 1F5-FNS-B05-1320 |  | B05 . AREA-2 -Raised Flooring | 6.25d | 2019-07-01 | 2019-07-06 | 1F5-FNS-B05-1310, 1F5-FNS-B05-1300 | 118.75d | 0d | Skilled Labour [171.6 h]; Unskilled Labour [57.2 h] | 17.44 | 1F4CVL | Arch'l | 2 | MB |
| 1F5-FNS-B05-1330 |  | B05 . AREA-2 -Install Ceiling | 10d | 2019-07-07 | 2019-07-15 | 1F5-FNS-B05-1300, 1F5-FNS-B05-1320, 1F5-FNS-B05-1310 | 118.75d | 0d | Unskilled Labour [171.6 h]; Skilled Labour [228.8 h] | 30.52 | 1F4CVL | Arch'l | 2 | MB |
| 1F5-FNS-B05-1335 |  | B05 . AREA-2 -Install Floor Tiles | 7.5d | 2019-07-16 | 2019-07-22 | 1F5-FNS-B05-1330 | 118.75d | 80.25d | Skilled Labour [257.4 h]; Unskilled Labour [128.7 h] | 29.43 | 1F4CVL | Arch'l | 2 | MB |
| 1F5-FNS-B05-1340 |  | B05 . AREA-2 -Ceiling Final Painting | 7.5d | 2019-10-10 | 2019-10-17 | MR380, 1F5-FNS-B05-1335 | 38.5d | 0d | Skilled Labour [214.5 h]; Unskilled Labour [128.7 h] | 26.16 | 1F4CVL | Arch'l | 2 | MB |
| 1F5-FNS-B05-1350 |  | B05 . AREA-2 -Walls Final Painting | 7.5d | 2019-10-17 | 2019-10-24 | 1F5-FNS-B05-1340, 1F5-FNS-B05-1225 | 38.5d | 0d | Unskilled Labour [128.7 h]; Skilled Labour [214.5 h] | 26.16 | 1F4CVL | Arch'l | 2 | MB |
| 1F5-FNS-B05-1365 |  | B05 . AREA-2 -Floor Epoxy Painting | 6.25d | 2019-10-24 | 2019-10-30 | 1F5-FNS-B05-1310, 1F5-FNS-B05-1340, 1F5-FNS-B05-1335, 1F5-FNS-B05-1350 | 80.75d | 0d | Skilled Labour [143 h]; Unskilled Labour [143 h] | 21.8 | 1F4CVL | Arch'l | 2 | MB |
| 1F5-FNS-B05-1370 |  | B05 . AREA-2 -Install Door & Hardware/Accessories | 3.75d | 2019-10-30 | 2019-11-03 | 1F5-FNS-B05-1365, 1F5-FNS-B05-1240 | 80.75d | 15d | Skilled Labour [57.2 h]; Unskilled Labour [57.2 h] | 8.72 | 1F4CVL | Arch'l | 2 | MB |

| ID | WBS | Activity | Type | Duration | Start | Finish | Predecessors | Total float | Free float | Calendar | Resources | Cost | 1F4 PROJECT | Discipline | AREA | LOCATION |
| --- | --- | --- | --- | --- | --- | --- | --- | --- | --- | --- | --- | --- | --- | --- | --- | --- |
|  | 3 | **B05 . AREA-1** |  |  | 2019-05-29 | 2019-11-20 |  |  |  |  |  |  |  |  |  |  |
|  | 4 | **BOH / FOH** |  |  | 2019-05-29 | 2019-11-20 |  |  |  |  |  |  |  |  |  |  |
| 1F5-FNS-B05-3470 |  | B05 . AREA-1 -Block Masonry |  | 15d | 2019-05-29 | 2019-06-15 | 1F5-FNS-B05-3040 FF, 1F5-FNS-B05-1270, 1F5-FNS-B05-1260 | 27.25d | 0d |  | Unskilled Labour [429 h]; Skilled Labour [686.4 h] | 85 | 1F4CVL | Arch'l | 1 | MB |
| 1F5-FNS-B05-3480 |  | B05 . AREA-1 -Interior Plaster & Rendering |  | 12.5d | 2019-06-10 | 2019-06-20 | 1F5-FNS-B05-3470 FF+6.25d, 1F5-FNS-B05-3050 FF | 27.25d | 0d |  | Unskilled Labour [257.4 h]; Skilled Labour [429 h] | 52.31 | 1F4CVL | Arch'l | 1 | MB |
| 1F5-FNS-B05-3490 |  | B05 . AREA-1 -Gypsum Partition and Panel |  | 7.5d | 2019-06-22 | 2019-06-27 | 1F5-FNS-B05-3480 | 27.25d | 0d |  | Skilled Labour [257.4 h]; Unskilled Labour [85.8 h] | 26.16 |  | Arch'l | 1 | MB |
| 1F5-FNS-B05-3500 |  | B05 . AREA-1 -Ceiling Painting 1st Coat |  | 6.25d | 2019-06-29 | 2019-07-03 | 1F5-FNS-B05-3490, 1F5-FNS-B05-3490 SS+3.75d, 1F5-FNS-B05-3470 | 27.25d | 0d |  | Skilled Labour [178.75 h]; Unskilled Labour [143 h] | 24.52 | 1F4CVL | Arch'l | 1 | MB |
| 1F5-FNS-B05-3510 |  | B05 . AREA-1 -Walls Painting 1st Coat |  | 7.5d | 2019-07-04 | 2019-07-10 | 1F5-FNS-B05-3500, 1F5-FNS-B05-3060 FF, 1F5-FNS-B05-3480 FS+2.5d | 27.25d | 0d |  | Skilled Labour [214.5 h]; Unskilled Labour [214.5 h] | 32.7 | 1F4CVL | Arch'l | 1 | MB |
| 1F5-FNS-B05-3515 |  | B05 . AREA-1 -Floor Concreted Screeding |  | 7.5d | 2019-07-11 | 2019-07-17 | 1F5-FNS-B05-3510, 1F5-FNS-B05-3070 FF, 1F5-FNS-B05-3510 SS+2.5d | 27.25d | 0d |  | Unskilled Labour [171.6 h]; Skilled Labour [171.6 h] | 26.16 | 1F4CVL | Arch'l | 1 | MB |
| 1F5-FNS-B05-3520 |  | B05 . AREA-1 -Raised Flooring |  | 6.25d | 2019-07-18 | 2019-07-23 | 1F5-FNS-B05-1320, 1F5-FNS-B05-3500, 1F5-FNS-B05-3515 | 107.5d | 0d |  | Skilled Labour [171.6 h]; Unskilled Labour [57.2 h] | 17.44 | 1F4CVL | Arch'l | 1 | MB |
| 1F5-FNS-B05-3530 |  | B05 . AREA-1 -Install Ceiling |  | 10d | 2019-07-24 | 2019-08-01 | 1F5-FNS-B05-3515, 1F5-FNS-B05-3520, 1F5-FNS-B05-3500 | 107.5d | 0d |  | Unskilled Labour [171.6 h]; Skilled Labour [228.8 h] | 30.52 | 1F4CVL | Arch'l | 1 | MB |
| 1F5-FNS-B05-3540 |  | B05 . AREA-1 -Install Floor Tiles |  | 7.5d | 2019-08-03 | 2019-08-08 | 1F5-FNS-B05-3530 | 107.5d | 80.25d |  | Skilled Labour [257.4 h]; Unskilled Labour [128.7 h] | 29.43 | 1F4CVL | Arch'l | 1 | MB |
| 1F5-FNS-B05-3550 |  | B05 . AREA-1 -Ceiling Final Painting |  | 7.5d | 2019-10-28 | 2019-11-04 | 1F5-FNS-B05-3500, 1F5-FNS-B05-3540, MR390 | 27.25d | 0d |  | Skilled Labour [214.5 h]; Unskilled Labour [128.7 h] | 26.16 | 1F4CVL | Arch'l | 1 | MB |
| 1F5-FNS-B05-3560 |  | B05 . AREA-1 -Walls Final Painting |  | 7.5d | 2019-11-04 | 2019-11-11 | 1F5-FNS-B05-3550, MR390, 1F5-FNS-B05-1350 | 27.25d | 0d |  | Unskilled Labour [128.7 h]; Skilled Labour [214.5 h] | 26.16 | 1F4CVL | Arch'l | 1 | MB |
| 1F5-FNS-B05-3570 |  | B05 . AREA-1 -Floor Epoxy Painting |  | 6.25d | 2019-11-11 | 2019-11-17 | 1F5-FNS-B05-3560, 1F5-FNS-B05-3075 FF, 1F5-FNS-B05-3550, 1F5-FNS-B05-3515 | 65.75d | 0d |  | Skilled Labour [143 h]; Unskilled Labour [143 h] | 21.8 | 1F4CVL | Arch'l | 1 | MB |
| 1F5-FNS-B05-3580 |  | B05 . AREA-1 -Install Door & Hardware/Accessories |  | 3.75d | 2019-11-17 | 2019-11-20 | 1F5-FNS-B05-1370, 1F5-FNS-B05-3570, 1F5-FNS-B05-3540 FF, LOE-SUM2-100 FF | 65.75d | 62d |  | Skilled Labour [57.2 h]; Unskilled Labour [57.2 h] | 8.72 | 1F4CVL | Arch'l | 1 | MB |
|  | 11 | **LOE Commodities ARCHL - B05 . Main Box . AREA-5 to AREA-1** |  |  | 2019-01-16 | 2019-11-17 |  |  |  |  |  |  |  |  |  |  |
| 1F5-FNS-B05-3040 |  | LOE Archl - B05 . Main Box . AREA-5 to AREA-1 - Blockworks | level of effort | 157.5d | 2019-01-16 | 2019-06-15 | 1F5-FNS-B05-870 SS | 27.25d | 0d |  | Block Work [1226.34 Square Meter] |  |  | Arch'l | 5 | MB |
| 1F5-FNS-B05-3050 |  | LOE Archl - B05 . Main Box . AREA-5 to AREA-1 - Plastering | level of effort | 155d | 2019-01-24 | 2019-06-20 | 1F5-FNS-B05-880 SS | 27.25d | 0d |  | Plaster Work [2728.8 Square Meter] |  |  | Arch'l | 5 | MB |
| 1F5-FNS-B05-3060 |  | LOE Archl - B05 . Main Box . AREA-5 to AREA-1 - Painting | level of effort | 156.25d | 2019-02-12 | 2019-07-10 | 1F5-FNS-B05-890 SS | 27.25d | 0d |  | Painting [2544 Square Meter] |  |  | Arch'l | 5 | MB |
| 1F5-FNS-B05-3070 |  | LOE Archl - B05 . Main Box . AREA-5 to AREA-1 - Screed | level of effort | 150d | 2019-02-25 | 2019-07-17 | 1F5-FNS-B05-910 SS | 27.25d | 0d |  | Screed Work [1102 Square Meter] |  |  | Arch'l | 5 | MB |
| 1F5-FNS-B05-3075 |  | LOE Archl - B05 . Main Box . AREA-5 to AREA-1 - Final Painting | level of effort | 163.75d | 2019-06-12 | 2019-11-17 | 1F5-FNS-B05-950 SS | 65.75d | 0d |  | Painting [848 Square Meter] |  |  | Arch'l | 5 | MB |
|  | 3 | **TECH'L LEVEL (B04)** |  |  | 2019-03-04 | 2019-11-07 |  |  |  |  |  |  |  |  |  |  |
| LOE-SUM2-110 |  | South . B04 - Archl Works | level of effort | 201.5d | 2019-03-04 | 2019-09-08 | 1F5-FNS-B04-090 SS | 133.5d | 0d | Saudi |  |  |  | Arch'l |  |  |
| LOE-SUM2-120 |  | Central . B04 - Archl Works | level of effort | 188d | 2019-04-07 | 2019-09-29 | 1F5-FNS-B04-530 SS | 114.5d | 0d | Saudi |  |  |  | Arch'l |  |  |
| LOE-SUM2-130 |  | North . B04 - Archl Works | level of effort | 209.25d | 2019-04-27 | 2019-11-07 | 1F5-FNS-B04-750 SS | 79.5d | 0d | Saudi |  |  |  | Arch'l |  |  |

| ID | WBS | Activity | Duration | Start | Finish | Predecessors | Total float | Free float | Resources | Cost | 1F4 PROJECT | Discipline | AREA | LOCATION |
| --- | --- | --- | --- | --- | --- | --- | --- | --- | --- | --- | --- | --- | --- | --- |
|  | 6 | **B04 . AREA-5** |  | 2019-03-04 | 2019-08-22 |  |  |  |  |  |  |  |  |  |
|  | 4 | **BOH / FOH** |  | 2019-03-04 | 2019-08-22 |  |  |  |  |  |  |  |  |  |
| 1F5-FNS-B04-090 |  | B04 . AREA-5 - Block Masonry | 15d | 2019-03-04 | 2019-03-17 | 1F5-FNS-B05-870, C1C1111F5S1420 FS+12.5d | 49.5d | 0d | Unskilled Labour [343.2 h]; Skilled Labour [686.4 h] | 78.47 | 1F4CVL | Arch'l | 5 | MB |
| 1F5-FNS-B04-100 |  | B04 . AREA-5 -Interior Plaster & Rendering | 12.5d | 2019-03-10 | 2019-03-20 | 1F5-FNS-B04-090 FF+3.75d | 106.25d | 0d | Skilled Labour [429 h]; Unskilled Labour [257.4 h] | 52.31 | 1F4CVL | Arch'l | 5 | MB |
| 1F5-FNS-B04-110 |  | B04 . AREA-5 -Gypsum Partition and Panel | 7.5d | 2019-03-21 | 2019-03-27 | 1F5-FNS-B04-100, 1F5-ARDWG740 | 106.25d | 0d | Skilled Labour [257.4 h]; Unskilled Labour [85.8 h] | 26.16 |  | Arch'l | 5 | MB |
| 1F5-FNS-B04-120 |  | B04 . AREA-5 -Ceiling Painting 1st Coat | 6.25d | 2019-03-28 | 2019-04-02 | 1F5-FNS-B04-110, 1F5-FNS-B04-090 | 106.25d | 0d | Skilled Labour [178.75 h]; Unskilled Labour [143 h] | 24.52 | 1F4CVL | Arch'l | 5 | MB |
| 1F5-FNS-B04-130 |  | B04 . AREA-5 -Walls Painting 1st Coat | 7.5d | 2019-04-03 | 2019-04-09 | 1F5-FNS-B04-120, 1F5-ARDWG750, 1F5-FNS-B04-100 FS+2.5d | 106.25d | 0d | Skilled Labour [214.5 h]; Unskilled Labour [214.5 h] | 32.7 | 1F4CVL | Arch'l | 5 | MB |
| 1F5-FNS-B04-140a |  | B04 . AREA-5 -Floor Concreted Screeding | 7.5d | 2019-04-10 | 2019-04-16 | 1F5-FNS-B04-130 | 106.25d | 0d | Unskilled Labour [171.6 h]; Skilled Labour [171.6 h] | 26.16 | 1F4CVL | Arch'l | 5 | MB |
| 1F5-FNS-B04-150 |  | B04 . AREA-5 -Raised Flooring | 6.25d | 2019-04-17 | 2019-04-22 | 1F5-PRO-GN-490, 1F5-FNS-B04-120, 1F5-FNS-B04-140a | 186d | 0d | Skilled Labour [171.6 h]; Unskilled Labour [57.2 h] | 17.44 | 1F4CVL | Arch'l | 5 | MB |
| 1F5-FNS-B04-160 |  | B04 . AREA-5 -Install Ceiling | 10d | 2019-04-23 | 2019-05-01 | 1F5-FNS-B04-140a, 1F5-FNS-B04-120, 1F5-FNS-B04-150, 1F5-ARDWG720 | 186.5d | 0d | Unskilled Labour [171.6 h]; Skilled Labour [228.8 h] | 30.52 | 1F4CVL | Arch'l | 5 | MB |
| 1F5-FNS-B04-170 |  | B04 . AREA-5 -Install Floor Tiles | 7.5d | 2019-05-02 | 2019-05-08 | 1F5-FNS-B04-160 | 186.5d | 80.25d | Skilled Labour [257.4 h]; Unskilled Labour [128.7 h] | 29.43 | 1F4CVL | Arch'l | 5 | MB |
| 1F5-FNS-B04-180 |  | B04 . AREA-5 -Ceiling Final Painting | 7.5d | 2019-07-27 | 2019-08-03 | MR410, 1F5-FNS-B04-170, 1F5-FNS-B04-120 | 106.25d | 0d | Skilled Labour [214.5 h]; Unskilled Labour [128.7 h] | 26.16 | 1F4CVL | Arch'l | 5 | MB |
| 1F5-FNS-B04-190 |  | B04 . AREA-5 -Walls Final Painting | 7.5d | 2019-08-03 | 2019-08-13 | 1F5-FNS-B04-180, MR410, 1F5-FNS-B04-170 | 106.25d | 0d | Unskilled Labour [128.7 h]; Skilled Labour [214.5 h] | 26.16 | 1F4CVL | Arch'l | 5 | MB |
| 1F5-FNS-B04-200 |  | B04 . AREA-5 -Floor Epoxy Painting | 6.25d | 2019-08-13 | 2019-08-19 | 1F5-FNS-B04-180, 1F5-FNS-B04-190, 1F5-FNS-B04-140a | 145.75d | 0d | Skilled Labour [143 h]; Unskilled Labour [143 h] | 21.8 | 1F4CVL | Arch'l | 5 | MB |
| 1F5-FNS-B04-210 |  | B04 . AREA-5 -Install Door Hardware/Accessories | 3.75d | 2019-08-19 | 2019-08-22 | 1F5-FNS-B04-200, 1F5-FNS-B04-170 FF, 1F5-ARDWG760 | 145.75d | 13.75d | Skilled Labour [57.2 h]; Unskilled Labour [57.2 h] | 8.72 | 1F4CVL | Arch'l | 5 | MB |
|  | 4 | **B04 . AREA-4** |  | 2019-03-18 | 2019-09-08 |  |  |  |  |  |  |  |  |  |
|  | 4 | **BOH / FOH** |  | 2019-03-18 | 2019-09-08 |  |  |  |  |  |  |  |  |  |
| 1F5-FNS-B04-310 |  | B04 . AREA-4 -Block Masonry | 15d | 2019-03-18 | 2019-03-31 | 1F5-FNS-B04-090 | 49.5d | 0d | Unskilled Labour [429 h]; Skilled Labour [686.4 h] | 85 | 1F4CVL | Arch'l | 4 | MB |
| 1F5-FNS-B04-320 |  | B04 . AREA-4 -Interior Plaster & Rendering | 12.5d | 2019-03-26 | 2019-04-06 | 1F5-FNS-B04-310 FF+6.25d, 1F5-FNS-B04-090 | 49.5d | 0d | Skilled Labour [429 h]; Unskilled Labour [257.4 h] | 52.31 | 1F4CVL | Arch'l | 4 | MB |
| 1F5-FNS-B04-330 |  | B04 . AREA-4 -Gypsum Partition and Panel | 7.5d | 2019-04-07 | 2019-04-13 | 1F5-FNS-B04-320 | 96.25d | 0d | Skilled Labour [257.4 h]; Unskilled Labour [85.8 h] | 26.16 |  | Arch'l | 4 | MB |
| 1F5-FNS-B04-340 |  | B04 . AREA-4 -Ceiling Painting 1st Coat | 6.25d | 2019-04-14 | 2019-04-18 | 1F5-FNS-B04-310, 1F5-FNS-B04-330 | 96.25d | 0d | Skilled Labour [178.75 h]; Unskilled Labour [143 h] | 24.52 | 1F4CVL | Arch'l | 4 | MB |
| 1F5-FNS-B04-350 |  | B04 . AREA-4 -Walls Painting 1st Coat | 7.5d | 2019-04-20 | 2019-04-25 | 1F5-FNS-B04-320, 1F5-FNS-B04-340 | 96.25d | 0d | Skilled Labour [214.5 h]; Unskilled Labour [214.5 h] | 32.7 | 1F4CVL | Arch'l | 4 | MB |
| 1F5-FNS-B04-360 |  | B04 . AREA-4 -Floor Concreted Screeding | 7.5d | 2019-04-27 | 2019-05-02 | 1F5-FNS-B04-350 | 96.25d | 0d | Unskilled Labour [171.6 h]; Skilled Labour [171.6 h] | 26.16 | 1F4CVL | Arch'l | 4 | MB |
| 1F5-FNS-B04-370 |  | B04 . AREA-4 -Raised Flooring | 6.25d | 2019-05-04 | 2019-05-08 | 1F5-FNS-B04-150, 1F5-FNS-B04-360 | 174.75d | 0d | Skilled Labour [171.6 h]; Unskilled Labour [57.2 h] | 17.44 | 1F4CVL | Arch'l | 4 | MB |
| 1F5-FNS-B04-380 |  | B04 . AREA-4 -Install Ceiling | 10d | 2019-05-09 | 2019-05-18 | 1F5-FNS-B04-340, 1F5-FNS-B04-360, 1F5-FNS-B04-370 | 176.5d | 0d | Unskilled Labour [171.6 h]; Skilled Labour [228.8 h] | 30.52 | 1F4CVL | Arch'l | 4 | MB |
| 1F5-FNS-B04-400 |  | B04 . AREA-4 -Install Floor Tiles | 7.5d | 2019-05-19 | 2019-05-25 | 1F5-FNS-B04-380, 1F5-FNS-B04-380 SS+3.75d | 176.5d | 80.25d | Skilled Labour [257.4 h]; Unskilled Labour [128.7 h] | 29.43 | 1F4CVL | Arch'l | 4 | MB |
| 1F5-FNS-B04-410 |  | B04 . AREA-4 -Ceiling Final Painting | 7.5d | 2019-08-15 | 2019-08-22 | 1F5-FNS-B04-340, 1F5-FNS-B04-400, MR400 | 96.25d | 0d | Skilled Labour [214.5 h]; Unskilled Labour [128.7 h] | 26.16 | 1F4CVL | Arch'l | 4 | MB |
| 1F5-FNS-B04-415 |  | B04 . AREA-4 -Walls Final Painting | 7.5d | 2019-08-22 | 2019-08-29 | 1F5-FNS-B04-190, MR400, 1F5-FNS-B04-410 | 96.25d | 0d | Unskilled Labour [128.7 h]; Skilled Labour [214.5 h] | 26.16 | 1F4CVL | Arch'l | 4 | MB |
| 1F5-FNS-B04-420 |  | B04 . AREA-4 -Floor Epoxy Painting | 6.25d | 2019-08-29 | 2019-09-04 | 1F5-FNS-B04-415, 1F5-FNS-B04-410, 1F5-FNS-B04-360 | 132d | 0d | Skilled Labour [143 h]; Unskilled Labour [143 h] | 21.8 | 1F4CVL | Arch'l | 4 | MB |
| 1F5-FNS-B04-430 |  | B04 . AREA-4 -Install Door Hardware/Accessories | 3.75d | 2019-09-04 | 2019-09-08 | 1F5-FNS-B04-210, 1F5-FNS-B04-420, LOE-SUM2-110 FF | 132d | 17.5d | Skilled Labour [57.2 h]; Unskilled Labour [57.2 h] | 8.72 | 1F4CVL | Arch'l | 4 | MB |

| ID | WBS | Activity | Duration | Start | Finish | Predecessors | Total float | Free float | Resources | Cost | 1F4 PROJECT | Discipline | AREA | LOCATION |
| --- | --- | --- | --- | --- | --- | --- | --- | --- | --- | --- | --- | --- | --- | --- |
|  | 3 | **B04 . AREA-3** |  | 2019-04-07 | 2019-09-29 |  |  |  |  |  |  |  |  |  |
|  | 4 | **BOH / FOH** |  | 2019-04-07 | 2019-09-29 |  |  |  |  |  |  |  |  |  |
| 1F5-FNS-B04-530 |  | B04 . AREA-3 -Block Masonry | 15d | 2019-04-07 | 2019-04-20 | 1F5-FNS-B04-310, 1F5-FNS-B04-320 | 49.5d | 0d | Unskilled Labour [429 h]; Skilled Labour [686.4 h] | 85 | 1F4CVL | Arch'l | 3 | MB |
| 1F5-FNS-B04-540 |  | B04 . AREA-3 -Interior Plaster & Rendering | 12.5d | 2019-04-15 | 2019-04-25 | 1F5-FNS-B04-530 FF+6.25d | 49.5d | 0d | Skilled Labour [429 h]; Unskilled Labour [257.4 h] | 52.31 | 1F4CVL | Arch'l | 3 | MB |
| 1F5-FNS-B04-550 |  | B04 . AREA-3 -Gypsum Partition and Panel | 7.5d | 2019-04-27 | 2019-05-02 | 1F5-FNS-B04-540 | 82.5d | 0d | Skilled Labour [257.4 h]; Unskilled Labour [85.8 h] | 26.16 |  | Arch'l | 3 | MB |
| 1F5-FNS-B04-560 |  | B04 . AREA-3 -Ceiling Painting 1st Coat | 6.25d | 2019-05-04 | 2019-05-08 | 1F5-FNS-B04-550, 1F5-FNS-B04-530 | 82.5d | 0d | Skilled Labour [178.75 h]; Unskilled Labour [143 h] | 24.52 | 1F4CVL | Arch'l | 3 | MB |
| 1F5-FNS-B04-570 |  | B04 . AREA-3 -Walls Painting 1st Coat | 7.5d | 2019-05-09 | 2019-05-15 | 1F5-FNS-B04-560 | 82.5d | 0d | Skilled Labour [214.5 h]; Unskilled Labour [214.5 h] | 32.7 | 1F4CVL | Arch'l | 3 | MB |
| 1F5-FNS-B04-575 |  | B04 . AREA-3 -Floor Concreted Screeding | 7.5d | 2019-05-16 | 2019-05-22 | 1F5-FNS-B04-570 SS+2.5d, 1F5-FNS-B04-570 | 82.5d | 0d | Unskilled Labour [171.6 h]; Skilled Labour [171.6 h] | 26.16 | 1F4CVL | Arch'l | 3 | MB |
| 1F5-FNS-B04-580 |  | B04 . AREA-3 -Raised Flooring | 6.25d | 2019-05-23 | 2019-05-28 | 1F5-FNS-B04-370, 1F5-FNS-B04-560, 1F5-FNS-B04-575 | 159.75d | 0d | Skilled Labour [171.6 h]; Unskilled Labour [57.2 h] | 17.44 | 1F4CVL | Arch'l | 3 | MB |
| 1F5-FNS-B04-590 |  | B04 . AREA-3 -Install Ceiling | 10d | 2019-05-29 | 2019-06-10 | 1F5-FNS-B04-580, 1F5-FNS-B04-575 | 162.75d | 0d | Unskilled Labour [171.6 h]; Skilled Labour [228.8 h] | 30.52 | 1F4CVL | Arch'l | 3 | MB |
| 1F5-FNS-B04-610 |  | B04 . AREA-3 -Install Floor Tiles | 7.5d | 2019-06-11 | 2019-06-17 | 1F5-FNS-B04-590, 1F5-FNS-B04-590 SS | 162.75d | 80.25d | Skilled Labour [257.4 h]; Unskilled Labour [128.7 h] | 29.43 | 1F4CVL | Arch'l | 3 | MB |
| 1F5-FNS-B04-620 |  | B04 . AREA-3 -Ceiling Final Painting | 7.5d | 2019-09-04 | 2019-09-11 | 1F5-FNS-B04-610, MR420 | 82.5d | 0d | Skilled Labour [214.5 h]; Unskilled Labour [128.7 h] | 26.16 | 1F4CVL | Arch'l | 3 | MB |
| 1F5-FNS-B04-630 |  | B04 . AREA-3 -Walls Final Painting | 7.5d | 2019-09-11 | 2019-09-18 | MR420, 1F5-FNS-B04-620, 1F5-FNS-B04-415 | 82.5d | 0d | Unskilled Labour [128.7 h]; Skilled Labour [214.5 h] | 26.16 | 1F4CVL | Arch'l | 3 | MB |
| 1F5-FNS-B04-640 |  | B04 . AREA-3 -Floor Epoxy Painting | 6.25d | 2019-09-18 | 2019-09-25 | 1F5-FNS-B04-630, 1F5-FNS-B04-620 | 114.5d | 0d | Skilled Labour [143 h]; Unskilled Labour [143 h] | 21.8 | 1F4CVL | Arch'l | 3 | MB |
| 1F5-FNS-B04-650 |  | B04 . AREA-3 -Install Door Hardware/Accessories | 3.75d | 2019-09-25 | 2019-09-29 | 1F5-FNS-B04-330, 1F5-FNS-B04-640, 1F5-FNS-B04-430, LOE-SUM2-120 FF | 114.5d | 17.5d | Skilled Labour [57.2 h]; Unskilled Labour [57.2 h] | 8.72 | 1F4CVL | Arch'l | 3 | MB |
|  | 2 | **B04 . AREA-2** |  | 2019-04-27 | 2019-10-19 |  |  |  |  |  |  |  |  |  |
|  | 4 | **BOH / FOH** |  | 2019-04-27 | 2019-10-19 |  |  |  |  |  |  |  |  |  |
| 1F5-FNS-B04-750 |  | B04 . AREA-2 -Block Masonry | 15d | 2019-04-27 | 2019-05-09 | 1F5-FNS-B04-530, 1F5-FNS-B04-540 | 49.5d | 0d | Unskilled Labour [429 h]; Skilled Labour [686.4 h] | 85 | 1F4CVL | Arch'l | 2 | MB |
| 1F5-FNS-B04-760 |  | B04 . AREA-2 -Interior Plaster & Rendering | 12.5d | 2019-05-05 | 2019-05-15 | 1F5-FNS-B04-750 FF+6.25d | 49.5d | 0d | Skilled Labour [429 h]; Unskilled Labour [257.4 h] | 52.31 | 1F4CVL | Arch'l | 2 | MB |
| 1F5-FNS-B04-770 |  | B04 . AREA-2 -Gypsum Partition and Panel | 7.5d | 2019-05-16 | 2019-05-22 | 1F5-FNS-B04-760 | 68.75d | 0d | Skilled Labour [257.4 h]; Unskilled Labour [85.8 h] | 26.16 |  | Arch'l | 2 | MB |
| 1F5-FNS-B04-780 |  | B04 . AREA-2 -Ceiling Painting 1st Coat | 6.25d | 2019-05-23 | 2019-05-28 | 1F5-FNS-B04-770, 1F5-FNS-B04-750 | 68.75d | 0d | Skilled Labour [178.75 h]; Unskilled Labour [143 h] | 24.52 | 1F4CVL | Arch'l | 2 | MB |
| 1F5-FNS-B04-790 |  | B04 . AREA-2 -Walls Painting 1st Coat | 7.5d | 2019-05-29 | 2019-06-08 | 1F5-FNS-B04-760 FS+2.5d, 1F5-FNS-B04-780 | 68.75d | 0d | Skilled Labour [214.5 h]; Unskilled Labour [214.5 h] | 32.7 | 1F4CVL | Arch'l | 2 | MB |
| 1F5-FNS-B04-795 |  | B04 . AREA-2 -Floor Concreted Screeding | 7.5d | 2019-06-09 | 2019-06-15 | 1F5-FNS-B04-790 | 68.75d | 0d | Unskilled Labour [171.6 h]; Skilled Labour [171.6 h] | 26.16 | 1F4CVL | Arch'l | 2 | MB |
| 1F5-FNS-B04-800 |  | B04 . AREA-2 -Raised Flooring | 6.25d | 2019-06-16 | 2019-06-20 | 1F5-FNS-B04-795, 1F5-FNS-B04-580 | 144.75d | 0d | Skilled Labour [171.6 h]; Unskilled Labour [57.2 h] | 17.44 | 1F4CVL | Arch'l | 2 | MB |
| 1F5-FNS-B04-810 |  | B04 . AREA-2 -Install Ceiling | 10d | 2019-06-22 | 2019-06-30 | 1F5-FNS-B04-800 | 149d | 0d | Unskilled Labour [171.6 h]; Skilled Labour [228.8 h] | 30.52 | 1F4CVL | Arch'l | 2 | MB |
| 1F5-FNS-B04-830 |  | B04 . AREA-2 -Install Floor Tiles | 7.5d | 2019-07-01 | 2019-07-07 | 1F5-FNS-B04-810 | 149d | 80.25d | Skilled Labour [257.4 h]; Unskilled Labour [128.7 h] | 29.43 | 1F4CVL | Arch'l | 2 | MB |
| 1F5-FNS-B04-840 |  | B04 . AREA-2 -Ceiling Final Painting | 7.5d | 2019-09-25 | 2019-10-02 | MR430, 1F5-FNS-B04-780, 1F5-FNS-B04-830 | 68.75d | 0d | Skilled Labour [214.5 h]; Unskilled Labour [128.7 h] | 26.16 | 1F4CVL | Arch'l | 2 | MB |
| 1F5-FNS-B04-850 |  | B04 . AREA-2 -Walls Final Painting | 7.5d | 2019-10-02 | 2019-10-09 | 1F5-FNS-B04-630, MR430, 1F5-FNS-B04-840 | 68.75d | 0d | Unskilled Labour [128.7 h]; Skilled Labour [214.5 h] | 26.16 | 1F4CVL | Arch'l | 2 | MB |
| 1F5-FNS-B04-860 |  | B04 . AREA-2 -Floor Epoxy Painting | 6.25d | 2019-10-09 | 2019-10-15 | 1F5-FNS-B04-840, 1F5-FNS-B04-1240 FF, 1F5-FNS-B04-850 | 97d | 0d | Skilled Labour [143 h]; Unskilled Labour [143 h] | 21.8 | 1F4CVL | Arch'l | 2 | MB |
| 1F5-FNS-B04-870 |  | B04 . AREA-2 -Install Door Hardware/Accessories | 3.75d | 2019-10-15 | 2019-10-19 | 1F5-FNS-B04-860, 1F5-FNS-B04-650, 1F5-FNS-B04-650 FF | 97d | 17.5d | Skilled Labour [57.2 h]; Unskilled Labour [57.2 h] | 8.72 | 1F4CVL | Arch'l | 2 | MB |

| ID | WBS | Activity | Type | Duration | Start | Finish | Predecessors | Total float | Free float | Calendar | Resources | Cost | 1F4 PROJECT | Discipline | AREA | LOCATION |
| --- | --- | --- | --- | --- | --- | --- | --- | --- | --- | --- | --- | --- | --- | --- | --- | --- |
|  | 1 | **B04 . AREA-1** |  |  | 2019-05-16 | 2019-11-07 |  |  |  |  |  |  |  |  |  |  |
|  | 4 | **BOH / FOH** |  |  | 2019-05-16 | 2019-11-07 |  |  |  |  |  |  |  |  |  |  |
| 1F5-FNS-B04-0970 |  | B04 . AREA-1 -Block Masonry |  | 15d | 2019-05-16 | 2019-05-29 | 1F5-FNS-B04-1200 FF, 1F5-FNS-B04-760, 1F5-FNS-B04-750 | 49.5d | 0d |  | Unskilled Labour [429 h]; Skilled Labour [686.4 h] | 85 | 1F4CVL | Arch'l | 1 | MB |
| 1F5-FNS-B04-0980 |  | B04 . AREA-1 -Interior Plaster & Rendering |  | 12.5d | 2019-05-25 | 2019-06-08 | 1F5-FNS-B04-0970 FF+6.25d, 1F5-FNS-B04-1210 FF | 49.5d | 0d |  | Skilled Labour [429 h]; Unskilled Labour [257.4 h] | 52.31 | 1F4CVL | Arch'l | 1 | MB |
| 1F5-FNS-B04-0990 |  | B04 . AREA-1 -Gypsum Partition and Panel |  | 7.5d | 2019-06-09 | 2019-06-15 | 1F5-FNS-B04-0980 | 49.5d | 0d |  | Skilled Labour [257.4 h]; Unskilled Labour [85.8 h] | 26.16 |  | Arch'l | 1 | MB |
| 1F5-FNS-B04-1000 |  | B04 . AREA-1 -Ceiling Painting 1st Coat |  | 6.25d | 2019-06-16 | 2019-06-20 | 1F5-FNS-B04-0970, 1F5-FNS-B04-0990 | 49.5d | 0d |  | Skilled Labour [178.75 h]; Unskilled Labour [143 h] | 24.52 | 1F4CVL | Arch'l | 1 | MB |
| 1F5-FNS-B04-1010 |  | B04 . AREA-1 -Walls Painting 1st Coat |  | 7.5d | 2019-06-22 | 2019-06-27 | 1F5-FNS-B04-1220 FF, 1F5-FNS-B04-1000 | 49.5d | 0d |  | Skilled Labour [214.5 h]; Unskilled Labour [214.5 h] | 32.7 | 1F4CVL | Arch'l | 1 | MB |
| 1F5-FNS-B04-1015 |  | B04 . AREA-1 -Floor Concreted Screeding |  | 7.5d | 2019-06-29 | 2019-07-04 | 1F5-FNS-B04-1010, 1F5-FNS-B04-1230 FF | 49.5d | 0d |  | Unskilled Labour [171.6 h]; Skilled Labour [171.6 h] | 26.16 | 1F4CVL | Arch'l | 1 | MB |
| 1F5-FNS-B04-1020 |  | B04 . AREA-1 -Raised Flooring |  | 6.25d | 2019-07-06 | 2019-07-10 | 1F5-FNS-B04-1000, 1F5-FNS-B04-1015, 1F5-FNS-B04-800 | 129.75d | 0d |  | Skilled Labour [171.6 h]; Unskilled Labour [57.2 h] | 17.44 | 1F4CVL | Arch'l | 1 | MB |
| 1F5-FNS-B04-1030 |  | B04 . AREA-1 -Install Ceiling |  | 10d | 2019-07-11 | 2019-07-20 | 1F5-FNS-B04-1020 | 129.75d | 0d |  | Unskilled Labour [171.6 h]; Skilled Labour [228.8 h] | 30.52 | 1F4CVL | Arch'l | 1 | MB |
| 1F5-FNS-B04-1050 |  | B04 . AREA-1 -Install Floor Tiles |  | 7.5d | 2019-07-21 | 2019-07-27 | 1F5-FNS-B04-1030 | 129.75d | 80.25d |  | Skilled Labour [257.4 h]; Unskilled Labour [128.7 h] | 29.43 | 1F4CVL | Arch'l | 1 | MB |
| 1F5-FNS-B04-1060 |  | B04 . AREA-1 -Ceiling Final Painting |  | 7.5d | 2019-10-15 | 2019-10-22 | 1F5-FNS-B04-1050, MR440 | 49.5d | 0d |  | Skilled Labour [214.5 h]; Unskilled Labour [128.7 h] | 26.16 | 1F4CVL | Arch'l | 1 | MB |
| 1F5-FNS-B04-1070 |  | B04 . AREA-1 -Walls Final Painting |  | 7.5d | 2019-10-22 | 2019-10-29 | 1F5-FNS-B04-850, 1F5-FNS-B04-1060, 1F5-FNS-B04-1050 | 55d | 0d |  | Unskilled Labour [128.7 h]; Skilled Labour [214.5 h] | 26.16 | 1F4CVL | Arch'l | 1 | MB |
| 1F5-FNS-B04-1080 |  | B04 . AREA-1 -Floor Epoxy Painting |  | 6.25d | 2019-10-29 | 2019-11-04 | 1F5-FNS-B04-1240 FF, 1F5-FNS-B04-1070, 1F5-FNS-B04-1060 | 79.5d | 0d |  | Skilled Labour [143 h]; Unskilled Labour [143 h] | 21.8 | 1F4CVL | Arch'l | 1 | MB |
| 1F5-FNS-B04-1090 |  | B04 . AREA-1 -Install Door Hardware/Accessories |  | 3.75d | 2019-11-04 | 2019-11-07 | 1F5-FNS-B04-1080, 1F5-FNS-B04-870, LOE-SUM2-130 FF | 79.5d | 75.75d |  | Skilled Labour [57.2 h]; Unskilled Labour [57.2 h] | 8.72 | 1F4CVL | Arch'l | 1 | MB |
|  | 11 | **LOE Commodities ARCHL - B04 . Main Box . AREA-5 to AREA-1** |  |  | 2019-03-04 | 2019-11-04 |  |  |  |  |  |  |  |  |  |  |
| 1F5-FNS-B04-1200 |  | LOE Archl - B04 . Main Box . AREA-5 to AREA-1 - Blockworks | level of effort | 93.75d | 2019-03-04 | 2019-05-29 | 1F5-FNS-B04-090 SS | 49.5d | 0d |  | Block Work [2014.71 Square Meter] |  |  | Arch'l | 5 | MB |
| 1F5-FNS-B04-1210 |  | LOE Archl - B04 . Main Box . AREA-5 to AREA-1 - Plastering | level of effort | 76.25d | 2019-03-26 | 2019-06-08 | 1F5-FNS-B04-320 SS | 49.5d | 0d |  | Plaster Work [4483.03 Square Meter] |  |  | Arch'l | 5 | MB |
| 1F5-FNS-B04-1220 |  | LOE Archl - B04 . Main Box . AREA-5 to AREA-1 - Painting | level of effort | 77.5d | 2019-04-14 | 2019-06-27 | 1F5-FNS-B04-340 SS | 49.5d | 0d |  | Painting [3362 Square Meter] |  |  | Arch'l | 5 | MB |
| 1F5-FNS-B04-1230 |  | LOE Archl - B04 . Main Box . AREA-5 to AREA-1 - Screed | level of effort | 71.25d | 2019-04-27 | 2019-07-04 | 1F5-FNS-B04-360 SS | 49.5d | 0d |  | Screed Work [1500 Square Meter] |  |  | Arch'l | 5 | MB |
| 1F5-FNS-B04-1240 |  | LOE Archl - B04 . Main Box . AREA-5 to AREA-1 - Final Painting | level of effort | 102.5d | 2019-07-27 | 2019-11-04 | 1F5-FNS-B04-180 SS, 1F5-FNS-B04-410 SS | 79.5d | 0d |  | Painting [1121 Square Meter] |  |  | Arch'l | 5 | MB |
|  | 4 | **CONCOURSE LEVEL (B03)** |  |  | 2019-01-30 | 2019-11-16 |  |  |  |  |  |  |  |  |  |  |
| LOE-SUM2-140 |  | South . B03 - Archl Works | level of effort | 236.5d | 2019-01-30 | 2019-09-08 | 1F5-FNS-B03-010 SS | 133.5d | 0d | Saudi |  |  |  | Arch'l |  |  |
| LOE-SUM2-150 |  | Central . B03 - Archl Works | level of effort | 188d | 2019-04-27 | 2019-10-19 | 1F5-FNS-B03-270 SS | 93.25d | 0d | Saudi |  |  |  | Arch'l |  |  |
| LOE-SUM2-160 |  | North . B03 - Archl Works | level of effort | 203d | 2019-05-11 | 2019-11-16 | 1F5-FNS-B03-400 SS | 70.75d | 0d | Saudi |  |  |  | Arch'l |  |  |

| ID | WBS | Activity | Duration | Start | Finish | Predecessors | Total float | Free float | Resources | Cost | 1F4 PROJECT | Discipline | AREA | LOCATION |
| --- | --- | --- | --- | --- | --- | --- | --- | --- | --- | --- | --- | --- | --- | --- |
|  | 1 | **B03 . AREA-5** |  | 2019-01-30 | 2019-07-20 |  |  |  |  |  |  |  |  |  |
|  | 4 | **BOH / FOH** |  | 2019-01-30 | 2019-07-20 |  |  |  |  |  |  |  |  |  |
| 1F5-FNS-B03-010 |  | B03 . AREA-5 -Block Masonry | 15d | 2019-01-30 | 2019-02-12 | 1F5-ARDWG770, C1C1111F5S1270 | 1.5d | 0d | Unskilled Labour [429 h]; Skilled Labour [686.4 h] | 85 | 1F4CVL | Arch'l | 5 | MB |
| 1F5-FNS-B03-020 |  | B03 . AREA-5 -Interior Plaster & Rendering | 12.5d | 2019-02-07 | 2019-02-18 | 1F5-FNS-B03-010 FF+6.25d, 1F5-ARDWG780 | 1.5d | 0d | Skilled Labour [429 h]; Unskilled Labour [257.4 h] | 52.31 | 1F4CVL | Arch'l | 5 | MB |
| 1F5-FNS-B03-030A |  | B03 . AREA-5 -Gypsum Partition and Panel | 7.5d | 2019-02-19 | 2019-02-25 | 1F5-ARDWG810, 1F5-FNS-B03-020 | 1.5d | 0d | Skilled Labour [257.4 h]; Unskilled Labour [85.8 h] | 26.16 |  | Arch'l | 5 | MB |
| 1F5-FNS-B03-040 |  | B03 . AREA-5 -Ceiling Painting 1st Coat | 6.25d | 2019-02-26 | 2019-03-03 | 1F5-FNS-B03-010, 1F5-FNS-B03-030A, 1F5-ARDWG790 | 1.5d | 0d | Skilled Labour [178.75 h]; Unskilled Labour [143 h] | 24.52 | 1F4CVL | Arch'l | 5 | MB |
| 1F5-FNS-B03-060 |  | B03 . AREA-5 -Walls Painting 1st Coat | 7.5d | 2019-03-04 | 2019-03-10 | 1F5-FNS-B03-020 FS+2.5d, 1F5-FNS-B03-040, 1F5-ARDWG820 | 1.5d | 0d | Skilled Labour [214.5 h]; Unskilled Labour [214.5 h] | 32.7 | 1F4CVL | Arch'l | 5 | MB |
| 1F5-FNS-B03-070 |  | B03 . AREA-5 -Floor Concreted Screeding | 7.5d | 2019-03-11 | 2019-03-17 | 1F5-FNS-B03-060 | 1.5d | 0d | Unskilled Labour [171.6 h]; Skilled Labour [171.6 h] | 26.16 | 1F4CVL | Arch'l | 5 | MB |
| 1F5-FNS-B03-075 |  | B03 . AREA-5 -Raised Flooring | 6.25d | 2019-03-31 | 2019-04-04 | 1F5-PRO-GN-490, 1F5-ARDWG800, 1F5-FNS-B03-040, 1F5-FNS-B03-070 | 228.75d | 0d | Skilled Labour [171.6 h]; Unskilled Labour [57.2 h] | 17.44 | 1F4CVL | Arch'l | 5 | MB |
| 1F5-FNS-B03-080 |  | B03 . AREA-5 -Install Ceiling | 10d | 2019-04-06 | 2019-04-14 | 1F5-FNS-B03-075, 1F5-FNS-B03-040 | 228.75d | 0d | Unskilled Labour [171.6 h]; Skilled Labour [228.8 h] | 30.52 | 1F4CVL | Arch'l | 5 | MB |
| 1F5-FNS-B03-090 |  | B03 . AREA-5 -Install Floor Tiles | 7.5d | 2019-04-15 | 2019-04-21 | 1F5-FNS-B03-080, 1F5-ARDWG800 | 228.75d | 66.5d | Skilled Labour [257.4 h]; Unskilled Labour [128.7 h] | 29.43 | 1F4CVL | Arch'l | 5 | MB |
| 1F5-FNS-B03-100 |  | B03 . AREA-5 -Ceiling Final Painting | 7.5d | 2019-06-26 | 2019-07-03 | MR460, 1F5-FNS-B03-090, 1F5-FNS-B03-040 | 162.25d | 0d | Skilled Labour [214.5 h]; Unskilled Labour [128.7 h] | 26.16 | 1F4CVL | Arch'l | 5 | MB |
| 1F5-FNS-B03-110 |  | B03 . AREA-5 -Walls Final Painting | 7.5d | 2019-07-03 | 2019-07-10 | MR460, 1F5-FNS-B03-100 | 168.75d | 0d | Unskilled Labour [128.7 h]; Skilled Labour [214.5 h] | 26.16 | 1F4CVL | Arch'l | 5 | MB |
| 1F5-FNS-B03-120 |  | B03 . AREA-5 -Floor Epoxy Painting | 6.25d | 2019-07-10 | 2019-07-16 | 1F5-FNS-B03-110, 1F5-FNS-B03-100 | 178.25d | 0d | Skilled Labour [143 h]; Unskilled Labour [143 h] | 21.8 | 1F4CVL | Arch'l | 5 | MB |
| 1F5-FNS-B03-130 |  | B03 . AREA-5 -Install Door Hardware/Accessories | 3.75d | 2019-07-16 | 2019-07-20 | 1F5-PRO-GN-510, 1F5-FNS-B03-120, 1F5-ARDWG830, 1F5-ARDWG830 FF | 178.25d | 46.25d | Skilled Labour [57.2 h]; Unskilled Labour [57.2 h] | 8.72 | 1F4CVL | Arch'l | 5 | MB |
|  | 2 | **B03 . AREA-4** |  | 2019-03-18 | 2019-09-08 |  |  |  |  |  |  |  |  |  |
|  | 4 | **BOH / FOH** |  | 2019-03-18 | 2019-09-08 |  |  |  |  |  |  |  |  |  |
| 1F5-FNS-B03-140 |  | B03 . AREA-4 -Block Masonry | 15d | 2019-03-18 | 2019-03-31 | 1F5-FNS-B03-010, 1F5-FNS-B03-070 | 1.5d | 0d | Unskilled Labour [429 h]; Skilled Labour [686.4 h] | 85 | 1F4CVL | Arch'l | 4 | MB |
| 1F5-FNS-B03-150 |  | B03 . AREA-4 -Interior Plaster & Rendering | 12.5d | 2019-03-26 | 2019-04-06 | 1F5-FNS-B03-140 FF+6.25d | 1.5d | 0d | Skilled Labour [429 h]; Unskilled Labour [257.4 h] | 52.31 | 1F4CVL | Arch'l | 4 | MB |
| 1F5-FNS-B03-160 |  | B03 . AREA-4 -Gypsum Partition and Panel | 7.5d | 2019-04-07 | 2019-04-13 | 1F5-FNS-B03-150 | 1.5d | 0d | Skilled Labour [257.4 h]; Unskilled Labour [85.8 h] | 26.16 |  | Arch'l | 4 | MB |
| 1F5-FNS-B03-170 |  | B03 . AREA-4 -Ceiling Painting 1st Coat | 6.25d | 2019-04-14 | 2019-04-18 | 1F5-FNS-B03-160 | 1.5d | 0d | Skilled Labour [178.75 h]; Unskilled Labour [143 h] | 24.52 | 1F4CVL | Arch'l | 4 | MB |
| 1F5-FNS-B03-180 |  | B03 . AREA-4 -Walls Painting 1st Coat | 7.5d | 2019-04-20 | 2019-04-25 | 1F5-FNS-B03-150 FS+2.5d, 1F5-FNS-B03-170 | 1.5d | 0d | Skilled Labour [214.5 h]; Unskilled Labour [214.5 h] | 32.7 | 1F4CVL | Arch'l | 4 | MB |
| 1F5-FNS-B03-200 |  | B03 . AREA-4 -Floor Concreted Screeding | 7.5d | 2019-04-27 | 2019-05-02 | 1F5-FNS-B03-180 | 1.5d | 0d | Unskilled Labour [171.6 h]; Skilled Labour [171.6 h] | 26.16 | 1F4CVL | Arch'l | 4 | MB |
| 1F5-FNS-B03-205 |  | B03 . AREA-4 -Raised Flooring | 6.25d | 2019-05-04 | 2019-05-08 | 1F5-FNS-B03-170, 1F5-FNS-B03-200 | 176.5d | 0d | Skilled Labour [171.6 h]; Unskilled Labour [57.2 h] | 17.44 | 1F4CVL | Arch'l | 4 | MB |
| 1F5-FNS-B03-210 |  | B03 . AREA-4 -Install Ceiling | 10d | 2019-05-09 | 2019-05-18 | 1F5-FNS-B03-205, 1F5-FNS-B03-170 | 176.5d | 0d | Unskilled Labour [171.6 h]; Skilled Labour [228.8 h] | 30.52 | 1F4CVL | Arch'l | 4 | MB |
| 1F5-FNS-B03-220 |  | B03 . AREA-4 -Install Floor Tiles | 7.5d | 2019-05-19 | 2019-05-25 | 1F5-FNS-B03-210 | 176.5d | 80.25d | Skilled Labour [257.4 h]; Unskilled Labour [128.7 h] | 29.43 | 1F4CVL | Arch'l | 4 | MB |
| 1F5-FNS-B03-230 |  | B03 . AREA-4 -Ceiling Final Painting | 7.5d | 2019-08-15 | 2019-08-22 | 1F5-FNS-B03-220, MR450 | 96.25d | 0d | Skilled Labour [214.5 h]; Unskilled Labour [128.7 h] | 26.16 | 1F4CVL | Arch'l | 4 | MB |
| 1F5-FNS-B03-240 |  | B03 . AREA-4 -Walls Final Painting | 7.5d | 2019-08-22 | 2019-08-29 | MR450, 1F5-FNS-B03-230 | 96.25d | 0d | Skilled Labour [214.5 h]; Unskilled Labour [128.7 h] | 26.16 | 1F4CVL | Arch'l | 4 | MB |
| 1F5-FNS-B03-250 |  | B03 . AREA-4 -Floor Epoxy Painting | 6.25d | 2019-08-29 | 2019-09-04 | 1F5-FNS-B03-240, 1F5-FNS-B03-230 | 132d | 0d | Skilled Labour [143 h]; Unskilled Labour [143 h] | 21.8 | 1F4CVL | Arch'l | 4 | MB |
| 1F5-FNS-B03-260 |  | B03 . AREA-4 -Install Door Hardware/Accessories | 3.75d | 2019-09-04 | 2019-09-08 | 1F5-FNS-B03-250, 1F5-FNS-B03-130, LOE-SUM2-140 FF | 132d | 38.75d | Skilled Labour [57.2 h]; Unskilled Labour [57.2 h] | 8.72 | 1F4CVL | Arch'l | 4 | MB |

| ID | WBS | Activity | Duration | Start | Finish | Predecessors | Total float | Free float | Resources | Cost | 1F4 PROJECT | Discipline | AREA | LOCATION |
| --- | --- | --- | --- | --- | --- | --- | --- | --- | --- | --- | --- | --- | --- | --- |
|  | 3 | **B03 . AREA-3** |  | 2019-04-27 | 2019-10-19 |  |  |  |  |  |  |  |  |  |
|  | 4 | **BOH / FOH** |  | 2019-04-27 | 2019-10-19 |  |  |  |  |  |  |  |  |  |
| 1F5-FNS-B03-270 |  | B03 . AREA-3 -Block Masonry | 15d | 2019-04-27 | 2019-05-09 | 1F5-FNS-B03-200 SS, 1F5-FNS-B03-140 | 1.5d | 0d | Unskilled Labour [429 h]; Skilled Labour [686.4 h] | 85 | 1F4CVL | Arch'l | 3 | MB |
| 1F5-FNS-B03-280 |  | B03 . AREA-3 -Interior Plaster & Rendering | 12.5d | 2019-05-05 | 2019-05-15 | 1F5-FNS-B03-270 FF+6.25d | 61.25d | 0d | Skilled Labour [429 h]; Unskilled Labour [257.4 h] | 52.31 | 1F4CVL | Arch'l | 3 | MB |
| 1F5-FNS-B03-290 |  | B03 . AREA-3 -Gypsum Partition and Panel | 7.5d | 2019-05-16 | 2019-05-22 | 1F5-FNS-B03-280 | 61.25d | 0d | Skilled Labour [257.4 h]; Unskilled Labour [85.8 h] | 26.16 |  | Arch'l | 3 | MB |
| 1F5-FNS-B03-300 |  | B03 . AREA-3 -Ceiling Painting 1st Coat | 6.25d | 2019-05-23 | 2019-05-28 | 1F5-FNS-B03-270, 1F5-FNS-B03-290 | 61.25d | 0d | Skilled Labour [178.75 h]; Unskilled Labour [143 h] | 24.52 | 1F4CVL | Arch'l | 3 | MB |
| 1F5-FNS-B03-320 |  | B03 . AREA-3 -Walls Painting 1st Coat | 7.5d | 2019-05-29 | 2019-06-08 | 1F5-FNS-B03-280 FS+2.5d, 1F5-FNS-B03-300 | 61.25d | 0d | Skilled Labour [214.5 h]; Unskilled Labour [214.5 h] | 32.7 | 1F4CVL | Arch'l | 3 | MB |
| 1F5-FNS-B03-330 |  | B03 . AREA-3 -Floor Concreted Screeding | 7.5d | 2019-06-09 | 2019-06-15 | 1F5-FNS-B03-320 | 61.25d | 0d | Unskilled Labour [171.6 h]; Skilled Labour [171.6 h] | 26.16 | 1F4CVL | Arch'l | 3 | MB |
| 1F5-FNS-B03-335 |  | B03 . AREA-3 -Raised Flooring | 6.25d | 2019-06-16 | 2019-06-20 | 1F5-FNS-B03-330 | 141.5d | 0d | Skilled Labour [171.6 h]; Unskilled Labour [57.2 h] | 17.44 | 1F4CVL | Arch'l | 3 | MB |
| 1F5-FNS-B03-340 |  | B03 . AREA-3 -Install Ceiling | 10d | 2019-06-22 | 2019-06-30 | 1F5-FNS-B03-335 | 141.5d | 0d | Unskilled Labour [171.6 h]; Skilled Labour [228.8 h] | 30.52 | 1F4CVL | Arch'l | 3 | MB |
| 1F5-FNS-B03-350 |  | B03 . AREA-3 -Install Floor Tiles | 7.5d | 2019-07-01 | 2019-07-07 | 1F5-FNS-B03-340 | 141.5d | 80.25d | Skilled Labour [257.4 h]; Unskilled Labour [128.7 h] | 29.43 | 1F4CVL | Arch'l | 3 | MB |
| 1F5-FNS-B03-360 |  | B03 . AREA-3 -Ceiling Final Painting | 7.5d | 2019-09-25 | 2019-10-02 | 1F5-FNS-B03-350, MR470 | 61.25d | 0d | Skilled Labour [214.5 h]; Unskilled Labour [128.7 h] | 26.16 | 1F4CVL | Arch'l | 3 | MB |
| 1F5-FNS-B03-370 |  | B03 . AREA-3 -Walls Final Painting | 7.5d | 2019-10-02 | 2019-10-09 | MR470, 1F5-FNS-B03-240, 1F5-FNS-B03-360 | 61.25d | 0d | Unskilled Labour [128.7 h]; Skilled Labour [214.5 h] | 26.16 | 1F4CVL | Arch'l | 3 | MB |
| 1F5-FNS-B03-380 |  | B03 . AREA-3 -Floor Epoxy Painting | 6.25d | 2019-10-09 | 2019-10-15 | 1F5-FNS-B03-360, 1F5-FNS-B03-370 | 93.25d | 0d | Skilled Labour [143 h]; Unskilled Labour [143 h] | 21.8 | 1F4CVL | Arch'l | 3 | MB |
| 1F5-FNS-B03-390 |  | B03 . AREA-3 -Install Door Hardware/Accessories | 3.75d | 2019-10-15 | 2019-10-19 | 1F5-FNS-B03-260, 1F5-FNS-B03-380, LOE-SUM2-150 FF | 93.25d | 11.25d | Skilled Labour [57.2 h]; Unskilled Labour [57.2 h] | 8.72 | 1F4CVL | Arch'l | 3 | MB |
|  | 4 | **B03 . AREA-2** |  | 2019-05-11 | 2019-11-02 |  |  |  |  |  |  |  |  |  |
|  | 4 | **BOH / FOH** |  | 2019-05-11 | 2019-11-02 |  |  |  |  |  |  |  |  |  |
| 1F5-FNS-B03-400 |  | B03 . AREA-2 -Block Masonry | 15d | 2019-05-11 | 2019-05-23 | C1C1111F5N1760, 1F5-FNS-B03-270 | 1.5d | 0d | Unskilled Labour [429 h]; Skilled Labour [686.4 h] | 85 | 1F4CVL | Arch'l | 2 | MB |
| 1F5-FNS-B03-410 |  | B03 . AREA-2 -Interior Plaster & Rendering | 12.5d | 2019-05-19 | 2019-05-29 | 1F5-FNS-B03-400 FF+6.25d | 1.5d | 0d | Skilled Labour [429 h]; Unskilled Labour [257.4 h] | 52.31 | 1F4CVL | Arch'l | 2 | MB |
| 1F5-FNS-B03-420 |  | B03 . AREA-2 -Gypsum Partition and Panel | 7.5d | 2019-05-30 | 2019-06-09 | 1F5-FNS-B03-410 | 1.5d | 0d | Skilled Labour [257.4 h]; Unskilled Labour [85.8 h] | 26.16 |  | Arch'l | 2 | MB |
| 1F5-FNS-B03-430 |  | B03 . AREA-2 -Ceiling Painting 1st Coat | 6.25d | 2019-06-10 | 2019-06-15 | 1F5-FNS-B03-420, 1F5-FNS-B03-400 | 1.5d | 0d | Skilled Labour [178.75 h]; Unskilled Labour [143 h] | 24.52 | 1F4CVL | Arch'l | 2 | MB |
| 1F5-FNS-B03-450 |  | B03 . AREA-2 -Walls Painting 1st Coat | 7.5d | 2019-06-16 | 2019-06-22 | 1F5-FNS-B03-430, 1F5-FNS-B03-410 FS+2.5d | 1.5d | 0d | Skilled Labour [214.5 h]; Unskilled Labour [214.5 h] | 32.7 | 1F4CVL | Arch'l | 2 | MB |
| 1F5-FNS-B03-460 |  | B03 . AREA-2 -Floor Concreted Screeding | 7.5d | 2019-06-23 | 2019-06-29 | 1F5-FNS-B03-450 | 1.5d | 0d | Unskilled Labour [171.6 h]; Skilled Labour [171.6 h] | 26.16 | 1F4CVL | Arch'l | 2 | MB |
| 1F5-FNS-B03-465 |  | B03 . AREA-2 -Raised Flooring | 6.25d | 2019-06-30 | 2019-07-04 | 1F5-FNS-B03-460, 1F5-FNS-B03-335, 1F5-FNS-B03-430 | 134d | 0d | Skilled Labour [171.6 h]; Unskilled Labour [57.2 h] | 17.44 | 1F4CVL | Arch'l | 2 | MB |
| 1F5-FNS-B03-470 |  | B03 . AREA-2 -Install Ceiling | 10d | 2019-07-06 | 2019-07-14 | 1F5-FNS-B03-465 | 134d | 0d | Unskilled Labour [171.6 h]; Skilled Labour [228.8 h] | 30.52 | 1F4CVL | Arch'l | 2 | MB |
| 1F5-FNS-B03-480 |  | B03 . AREA-2 -Install Floor Tiles | 7.5d | 2019-07-15 | 2019-07-21 | 1F5-FNS-B03-470 | 134d | 80.25d | Skilled Labour [257.4 h]; Unskilled Labour [128.7 h] | 29.43 | 1F4CVL | Arch'l | 2 | MB |
| 1F5-FNS-B03-490 |  | B03 . AREA-2 -Ceiling Final Painting | 7.5d | 2019-10-09 | 2019-10-16 | MR480, 1F5-FNS-B03-480 | 53.75d | 0d | Skilled Labour [214.5 h]; Unskilled Labour [128.7 h] | 26.16 | 1F4CVL | Arch'l | 2 | MB |
| 1F5-FNS-B03-500 |  | B03 . AREA-2 -Walls Final Painting | 7.5d | 2019-10-16 | 2019-10-23 | 1F5-FNS-B03-370, MR480, 1F5-FNS-B03-490 | 53.75d | 0d | Unskilled Labour [128.7 h]; Skilled Labour [214.5 h] | 26.16 | 1F4CVL | Arch'l | 2 | MB |
| 1F5-FNS-B03-510 |  | B03 . AREA-2 -Floor Epoxy Painting | 6.25d | 2019-10-23 | 2019-10-29 | 1F5-FNS-B03-500, 1F5-FNS-B03-490 | 82d | 0d | Skilled Labour [143 h]; Unskilled Labour [143 h] | 21.8 | 1F4CVL | Arch'l | 2 | MB |
| 1F5-FNS-B03-520 |  | B03 . AREA-2 -Install Door Hardware/Accessories | 3.75d | 2019-10-29 | 2019-11-02 | 1F5-FNS-B03-510, 1F5-FNS-B03-390 | 82d | 11.25d | Skilled Labour [57.2 h]; Unskilled Labour [57.2 h] | 8.72 | 1F4CVL | Arch'l | 2 | MB |

| ID | WBS | Activity | Type | Duration | Start | Finish | Predecessors | Total float | Free float | Calendar | Resources | Cost | 1F4 PROJECT | Discipline | AREA | LOCATION |
| --- | --- | --- | --- | --- | --- | --- | --- | --- | --- | --- | --- | --- | --- | --- | --- | --- |
|  | 5 | **B03 . AREA-1** |  |  | 2019-05-25 | 2019-11-16 |  |  |  |  |  |  |  |  |  |  |
|  | 4 | **BOH / FOH** |  |  | 2019-05-25 | 2019-11-16 |  |  |  |  |  |  |  |  |  |  |
| 1F5-FNS-B03-530 |  | B03 . AREA-1 -Block Masonry |  | 15d | 2019-05-25 | 2019-06-10 | 1F5-FNS-B03-400, 1F5-FNS-B03-660 FF | 39.75d | 0d |  | Unskilled Labour [429 h]; Skilled Labour [686.4 h] | 85 | 1F4CVL | Arch'l | 1 | MB |
| 1F5-FNS-B03-540 |  | B03 . AREA-1 -Interior Plaster & Rendering |  | 12.5d | 2019-06-02 | 2019-06-16 | 1F5-FNS-B03-530 FF+6.25d, 1F5-FNS-B03-670 FF | 39.75d | 0d |  | Skilled Labour [429 h]; Unskilled Labour [257.4 h] | 52.31 | 1F4CVL | Arch'l | 1 | MB |
| 1F5-FNS-B03-550 |  | B03 . AREA-1 -Gypsum Partition and Panel |  | 7.5d | 2019-06-17 | 2019-06-23 | 1F5-FNS-B03-540 | 39.75d | 0d |  | Skilled Labour [257.4 h]; Unskilled Labour [85.8 h] | 26.16 |  | Arch'l | 1 | MB |
| 1F5-FNS-B03-560 |  | B03 . AREA-1 -Ceiling Painting 1st Coat |  | 6.25d | 2019-06-24 | 2019-06-29 | 1F5-FNS-B03-530, 1F5-FNS-B03-550 | 39.75d | 0d |  | Skilled Labour [178.75 h]; Unskilled Labour [143 h] | 24.52 | 1F4CVL | Arch'l | 1 | MB |
| 1F5-FNS-B03-580 |  | B03 . AREA-1 -Walls Painting 1st Coat |  | 7.5d | 2019-06-30 | 2019-07-06 | 1F5-FNS-B03-680 FF, 1F5-FNS-B03-540 FS+2.5d, 1F5-FNS-B03-560 | 39.75d | 0d |  | Skilled Labour [214.5 h]; Unskilled Labour [214.5 h] | 32.7 | 1F4CVL | Arch'l | 1 | MB |
| 1F5-FNS-B03-590 |  | B03 . AREA-1 -Floor Concreted Screeding |  | 7.5d | 2019-07-07 | 2019-07-13 | 1F5-FNS-B03-690 FF, 1F5-FNS-B03-580 | 39.75d | 0d |  | Unskilled Labour [171.6 h]; Skilled Labour [171.6 h] | 26.16 | 1F4CVL | Arch'l | 1 | MB |
| 1F5-FNS-B03-595 |  | B03 . AREA-1 -Raised Flooring |  | 6.25d | 2019-07-14 | 2019-07-18 | 1F5-FNS-B03-590 | 120d | 0d |  | Skilled Labour [171.6 h]; Unskilled Labour [57.2 h] | 17.44 | 1F4CVL | Arch'l | 1 | MB |
| 1F5-FNS-B03-600 |  | B03 . AREA-1 -Install Ceiling |  | 10d | 2019-07-20 | 2019-07-28 | 1F5-FNS-B03-590, 1F5-FNS-B03-595 | 120d | 0d |  | Unskilled Labour [171.6 h]; Skilled Labour [228.8 h] | 30.52 | 1F4CVL | Arch'l | 1 | MB |
| 1F5-FNS-B03-610 |  | B03 . AREA-1 -Install Floor Tiles |  | 7.5d | 2019-07-29 | 2019-08-04 | 1F5-FNS-B03-600 | 120d | 80.25d |  | Skilled Labour [257.4 h]; Unskilled Labour [128.7 h] | 29.43 | 1F4CVL | Arch'l | 1 | MB |
| 1F5-FNS-B03-620 |  | B03 . AREA-1 -Ceiling Final Painting |  | 7.5d | 2019-10-23 | 2019-10-30 | 1F5-FNS-B03-610, MR490 | 39.75d | 0d |  | Skilled Labour [214.5 h]; Unskilled Labour [128.7 h] | 26.16 | 1F4CVL | Arch'l | 1 | MB |
| 1F5-FNS-B03-630 |  | B03 . AREA-1 -Walls Final Painting |  | 7.5d | 2019-10-30 | 2019-11-06 | 1F5-FNS-B03-620, 1F5-FNS-B03-500, MR490 | 46.25d | 0d |  | Unskilled Labour [128.7 h]; Skilled Labour [214.5 h] | 26.16 | 1F4CVL | Arch'l | 1 | MB |
| 1F5-FNS-B03-640 |  | B03 . AREA-1 -Floor Epoxy Painting |  | 6.25d | 2019-11-06 | 2019-11-12 | 1F5-FNS-B03-630, 1F5-FNS-B03-620, 1F5-FNS-B03-700 FF | 70.75d | 0d |  | Skilled Labour [143 h]; Unskilled Labour [143 h] | 21.8 | 1F4CVL | Arch'l | 1 | MB |
| 1F5-FNS-B03-650 |  | B03 . AREA-1 -Install Door Hardware/Accessories |  | 3.75d | 2019-11-12 | 2019-11-16 | 1F5-FNS-B03-640, 1F5-FNS-B03-520, LOE-SUM2-160 FF | 70.75d | 67d |  | Skilled Labour [57.2 h]; Unskilled Labour [57.2 h] | 8.72 | 1F4CVL | Arch'l | 1 | MB |
|  | 11 | **LOE Commodities ARCHL - B03 . Main Box . AREA-5 to AREA-1** |  |  | 2019-01-30 | 2019-11-12 |  |  |  |  |  |  |  |  |  |  |
| 1F5-FNS-B03-660 |  | LOE Archl - B03 . Main Box . AREA-5 to AREA-1 - Blockworks | level of effort | 137.5d | 2019-01-30 | 2019-06-10 | 1F5-FNS-B03-010 SS | 39.75d | 0d |  | Block Work [1524.17 Square Meter] |  |  | Arch'l | 5 | MB |
| 1F5-FNS-B03-670 |  | LOE Archl - B03 . Main Box . AREA-5 to AREA-1 - Plastering | level of effort | 135d | 2019-02-07 | 2019-06-16 | 1F5-FNS-B03-020 SS | 39.75d | 0d |  | Plaster Work [3391.51 Square Meter] |  |  | Arch'l | 5 | MB |
| 1F5-FNS-B03-680 |  | LOE Archl - B03 . Main Box . AREA-5 to AREA-1 - Painting | level of effort | 136.25d | 2019-02-26 | 2019-07-06 | 1F5-FNS-B03-040 SS | 39.75d | 0d |  | Painting [2047 Square Meter] |  |  | Arch'l | 5 | MB |
| 1F5-FNS-B03-690 |  | LOE Archl - B03 . Main Box . AREA-5 to AREA-1 - Screed | level of effort | 130d | 2019-03-11 | 2019-07-13 | 1F5-FNS-B03-070 SS | 39.75d | 0d |  | Screed Work [987 Square Meter] |  |  | Arch'l | 5 | MB |
| 1F5-FNS-B03-700 |  | LOE Archl - B03 . Main Box . AREA-5 to AREA-1 - Final Painting | level of effort | 143.75d | 2019-06-26 | 2019-11-12 | 1F5-FNS-B03-100 SS | 70.75d | 0d |  | Painting [682 Square Meter] |  |  | Arch'l | 5 | MB |
|  | 5 | **TV LOUVER LEVEL (B02)** |  |  | 2019-04-01 | 2019-12-15 |  |  |  |  |  |  |  |  |  |  |
| LOE-SUM2-170 |  | South . B02 - Archl Works | level of effort | 203d | 2019-04-01 | 2019-10-07 | 1F5-FNS-B02-010 SS | 89.5d | 0d | Saudi |  |  |  | Arch'l |  |  |
| LOE-SUM2-180 |  | Central . B02 - Archl Works | level of effort | 188d | 2019-05-26 | 2019-11-17 | 1F5-FNS-B02-280 SS | 49.5d | 0d | Saudi |  |  |  | Arch'l |  |  |
| LOE-SUM2-190 |  | North . B02 - Archl Works | level of effort | 199.25d | 2019-06-12 | 2019-12-15 | 1F5-FNS-B02-410 SS | 27d | 0d | Saudi |  |  |  | Arch'l |  |  |

| ID | WBS | Activity | Duration | Start | Finish | Predecessors | Total float | Free float | Resources | Cost | 1F4 PROJECT | Discipline | AREA | LOCATION |
| --- | --- | --- | --- | --- | --- | --- | --- | --- | --- | --- | --- | --- | --- | --- |
|  | 1 | **B02 . AREA-5** |  | 2019-04-01 | 2019-09-22 |  |  |  |  |  |  |  |  |  |
|  | 4 | **BOH / FOH** |  | 2019-04-01 | 2019-09-22 |  |  |  |  |  |  |  |  |  |
| 1F5-FNS-B02-010 |  | B02 . AREA-5 -Block Masonry | 15d | 2019-04-01 | 2019-04-14 | C1C1111F5S1470, C1C1111F5S1570 FS+10d, 1F5-ARDWG840, 1F5-FNS-B03-010 | 0.75d | 0d | Unskilled Labour [429 h]; Skilled Labour [686.4 h] | 85 | 1F4CVL | Arch'l | 5 | MB |
| 1F5-FNS-B02-020 |  | B02 . AREA-5 -Interior Plaster & Rendering | 12.5d | 2019-04-09 | 2019-04-20 | 1F5-ARDWG850, 1F5-FNS-B02-010 FF+6.25d | 97.25d | 0d | Skilled Labour [429 h]; Unskilled Labour [257.4 h] | 52.31 | 1F4CVL | Arch'l | 5 | MB |
| 1F5-FNS-B02-030 |  | B02 . AREA-5 -Gypsum Partition and Panel | 7.5d | 2019-04-21 | 2019-04-27 | 1F5-FNS-B02-020 | 97.25d | 0d | Skilled Labour [257.4 h]; Unskilled Labour [85.8 h] | 26.16 |  | Arch'l | 5 | MB |
| 1F5-FNS-B02-040 |  | B02 . AREA-5 -Ceiling Painting 1st Coat | 6.25d | 2019-04-28 | 2019-05-02 | 1F5-FNS-B02-010, 1F5-FNS-B02-030 | 97.25d | 0d | Skilled Labour [178.75 h]; Unskilled Labour [143 h] | 24.52 | 1F4CVL | Arch'l | 5 | MB |
| 1F5-FNS-B02-060 |  | B02 . AREA-5 -Walls Painting 1st Coat | 7.5d | 2019-05-04 | 2019-05-09 | 1F5-ARDWG890, 1F5-FNS-B02-040 | 97.25d | 0d | Skilled Labour [214.5 h]; Unskilled Labour [214.5 h] | 32.7 | 1F4CVL | Arch'l | 5 | MB |
| 1F5-FNS-B02-070 |  | B02 . AREA-5 -Floor Concreted Screeding | 7.5d | 2019-05-11 | 2019-05-16 | 1F5-FNS-B02-060 | 97.25d | 0d | Unskilled Labour [171.6 h]; Skilled Labour [171.6 h] | 26.16 | 1F4CVL | Arch'l | 5 | MB |
| 1F5-FNS-B02-075 |  | B02 . AREA-5 -Raised Flooring | 6.25d | 2019-05-18 | 2019-05-22 | 1F5-FNS-B02-070, 1F5-ARDWG870, 1F5-PRO-GN-490 | 177.5d | 0d | Skilled Labour [171.6 h]; Unskilled Labour [57.2 h] | 17.44 | 1F4CVL | Arch'l | 5 | MB |
| 1F5-FNS-B02-080 |  | B02 . AREA-5 -Install Ceiling | 10d | 2019-05-23 | 2019-06-01 | 1F5-FNS-B02-075 | 177.5d | 0d | Unskilled Labour [171.6 h]; Skilled Labour [228.8 h] | 30.52 | 1F4CVL | Arch'l | 5 | MB |
| 1F5-FNS-B02-090 |  | B02 . AREA-5 -Install Floor Tiles | 7.5d | 2019-06-02 | 2019-06-11 | 1F5-FNS-B02-080 | 177.5d | 80.25d | Skilled Labour [257.4 h]; Unskilled Labour [128.7 h] | 29.43 | 1F4CVL | Arch'l | 5 | MB |
| 1F5-FNS-B02-100 |  | B02 . AREA-5 -Ceiling Final Painting | 7.5d | 2019-08-29 | 2019-09-05 | MR510, 1F5-FNS-B02-090, MR560 | 97.25d | 0d | Skilled Labour [214.5 h]; Unskilled Labour [128.7 h] | 26.16 | 1F4CVL | Arch'l | 5 | MB |
| 1F5-FNS-B02-110 |  | B02 . AREA-5 -Walls Final Painting | 7.5d | 2019-09-05 | 2019-09-12 | 1F5-FNS-B02-100, MR510 | 100.75d | 0d | Unskilled Labour [128.7 h]; Skilled Labour [214.5 h] | 26.16 | 1F4CVL | Arch'l | 5 | MB |
| 1F5-FNS-B02-120 |  | B02 . AREA-5 -Floor Epoxy Painting | 6.25d | 2019-09-12 | 2019-09-18 | 1F5-FNS-B02-100, 1F5-FNS-B02-110 | 100.75d | 0d | Skilled Labour [143 h]; Unskilled Labour [143 h] | 21.8 | 1F4CVL | Arch'l | 5 | MB |
| 1F5-FNS-B02-130 |  | B02 . AREA-5 -Install Door Hardware/Accessories | 3.75d | 2019-09-18 | 2019-09-22 | 1F5-FNS-B02-120, 1F5-ARDWG970, 1F5-ARDWG900 | 100.75d | 11.25d | Skilled Labour [57.2 h]; Unskilled Labour [57.2 h] | 8.72 | 1F4CVL | Arch'l | 5 | MB |
|  | 2 | **B02 . AREA-4** |  | 2019-04-15 | 2019-10-07 |  |  |  |  |  |  |  |  |  |
|  | 4 | **BOH / FOH** |  | 2019-04-15 | 2019-10-07 |  |  |  |  |  |  |  |  |  |
| 1F5-FNS-B02-140 |  | B02 . AREA-4 -Block Masonry | 15d | 2019-04-15 | 2019-04-28 | 1F5-FNS-B02-010 | 0.75d | 0d | Unskilled Labour [429 h]; Skilled Labour [686.4 h] | 85 | 1F4CVL | Arch'l | 4 | MB |
| 1F5-FNS-B02-150 |  | B02 . AREA-4 -Interior Plaster & Rendering | 12.5d | 2019-04-23 | 2019-05-04 | 1F5-FNS-B02-140 FF+6.25d | 0.75d | 0d | Skilled Labour [429 h]; Unskilled Labour [257.4 h] | 52.31 | 1F4CVL | Arch'l | 4 | MB |
| 1F5-FNS-B02-160 |  | B02 . AREA-4 -Gypsum Partition and Panel | 7.5d | 2019-05-05 | 2019-05-11 | 1F5-FNS-B02-150 | 0.75d | 0d | Skilled Labour [257.4 h]; Unskilled Labour [85.8 h] | 26.16 |  | Arch'l | 4 | MB |
| 1F5-FNS-B02-170 |  | B02 . AREA-4 -Ceiling Painting 1st Coat | 6.25d | 2019-05-12 | 2019-05-16 | 1F5-FNS-B02-160 | 0.75d | 0d | Skilled Labour [178.75 h]; Unskilled Labour [143 h] | 24.52 | 1F4CVL | Arch'l | 4 | MB |
| 1F5-FNS-B02-190 |  | B02 . AREA-4 -Walls Painting 1st Coat | 7.5d | 2019-05-18 | 2019-05-23 | 1F5-FNS-B02-170 | 0.75d | 0d | Skilled Labour [214.5 h]; Unskilled Labour [214.5 h] | 32.7 | 1F4CVL | Arch'l | 4 | MB |
| 1F5-FNS-B02-200 |  | B02 . AREA-4 -Floor Concreted Screeding | 7.5d | 2019-05-25 | 2019-05-30 | 1F5-FNS-B02-190 | 0.75d | 0d | Unskilled Labour [171.6 h]; Skilled Labour [171.6 h] | 26.16 | 1F4CVL | Arch'l | 4 | MB |
| 1F5-FNS-B02-210 |  | B02 . AREA-4 -Raised Flooring | 6.25d | 2019-06-01 | 2019-06-09 | 1F5-FNS-B02-200 | 162.5d | 0d | Skilled Labour [171.6 h]; Unskilled Labour [57.2 h] | 17.44 | 1F4CVL | Arch'l | 4 | MB |
| 1F5-FNS-B02-220 |  | B02 . AREA-4 -Install Ceiling | 10d | 2019-06-10 | 2019-06-18 | 1F5-FNS-B02-210 | 162.5d | 0d | Unskilled Labour [171.6 h]; Skilled Labour [228.8 h] | 30.52 | 1F4CVL | Arch'l | 4 | MB |
| 1F5-FNS-B02-230 |  | B02 . AREA-4 -Install Floor Tiles | 7.5d | 2019-06-19 | 2019-06-25 | 1F5-FNS-B02-220 | 162.5d | 80.25d | Skilled Labour [257.4 h]; Unskilled Labour [128.7 h] | 29.43 | 1F4CVL | Arch'l | 4 | MB |
| 1F5-FNS-B02-240 |  | B02 . AREA-4 -Ceiling Final Painting | 7.5d | 2019-09-12 | 2019-09-19 | MR550, 1F5-FNS-B02-230, MR500 | 82.25d | 0d | Skilled Labour [214.5 h]; Unskilled Labour [128.7 h] | 26.16 | 1F4CVL | Arch'l | 4 | MB |
| 1F5-FNS-B02-250 |  | B02 . AREA-4 -Walls Final Painting | 7.5d | 2019-09-19 | 2019-09-28 | MR550, 1F5-FNS-B02-240, MR500 | 88.75d | 0d | Unskilled Labour [128.7 h]; Skilled Labour [214.5 h] | 26.16 | 1F4CVL | Arch'l | 4 | MB |
| 1F5-FNS-B02-260 |  | B02 . AREA-4 -Floor Epoxy Painting | 6.25d | 2019-09-28 | 2019-10-03 | 1F5-FNS-B02-250 | 89.5d | 0d | Skilled Labour [143 h]; Unskilled Labour [143 h] | 21.8 | 1F4CVL | Arch'l | 4 | MB |
| 1F5-FNS-B02-270 |  | B02 . AREA-4 -Install Door Hardware/Accessories | 3.75d | 2019-10-03 | 2019-10-07 | 1F5-FNS-B02-130, 1F5-FNS-B02-260, LOE-SUM2-170 FF | 89.5d | 40d | Skilled Labour [57.2 h]; Unskilled Labour [57.2 h] | 8.72 | 1F4CVL | Arch'l | 4 | MB |

| ID | WBS | Activity | Duration | Start | Finish | Predecessors | Total float | Free float | Resources | Cost | 1F4 PROJECT | Discipline | AREA | LOCATION |
| --- | --- | --- | --- | --- | --- | --- | --- | --- | --- | --- | --- | --- | --- | --- |
|  | 3 | **B02 . AREA-3** |  | 2019-05-26 | 2019-11-17 |  |  |  |  |  |  |  |  |  |
|  | 4 | **BOH / FOH** |  | 2019-05-26 | 2019-11-17 |  |  |  |  |  |  |  |  |  |
| 1F5-FNS-B02-280 |  | B02 . AREA-3 -Block Masonry | 15d | 2019-05-26 | 2019-06-11 | 1F5-FNS-B02-200 SS, C1C1111F5C1880, 1F5-FNS-B02-140, C1C1111F5C1950 | -0.5d | 0d | Unskilled Labour [429 h]; Skilled Labour [686.4 h] | 85 | 1F4CVL | Arch'l | 3 | MB |
| 1F5-FNS-B02-290 |  | B02 . AREA-3 -Interior Plaster & Rendering | 12.5d | 2019-06-03 | 2019-06-17 | 1F5-FNS-B02-280 FF+6.25d | 37.5d | 0d | Skilled Labour [429 h]; Unskilled Labour [257.4 h] | 52.31 | 1F4CVL | Arch'l | 3 | MB |
| 1F5-FNS-B02-300 |  | B02 . AREA-3 -Gypsum Partition and Panel | 7.5d | 2019-06-18 | 2019-06-24 | 1F5-FNS-B02-290 | 37.5d | 0d | Skilled Labour [257.4 h]; Unskilled Labour [85.8 h] | 26.16 |  | Arch'l | 3 | MB |
| 1F5-FNS-B02-310 |  | B02 . AREA-3 -Ceiling Painting 1st Coat | 6.25d | 2019-06-25 | 2019-06-30 | 1F5-FNS-B02-280, 1F5-FNS-B02-300 | 37.5d | 0d | Skilled Labour [178.75 h]; Unskilled Labour [143 h] | 24.52 | 1F4CVL | Arch'l | 3 | MB |
| 1F5-FNS-B02-330 |  | B02 . AREA-3 -Walls Painting 1st Coat | 7.5d | 2019-07-01 | 2019-07-07 | 1F5-FNS-B02-290 FS+2.5d, 1F5-FNS-B02-310 | 37.5d | 0d | Skilled Labour [214.5 h]; Unskilled Labour [214.5 h] | 32.7 | 1F4CVL | Arch'l | 3 | MB |
| 1F5-FNS-B02-340 |  | B02 . AREA-3 -Floor Concreted Screeding | 7.5d | 2019-07-08 | 2019-07-14 | 1F5-FNS-B02-330 | 37.5d | 0d | Unskilled Labour [171.6 h]; Skilled Labour [171.6 h] | 26.16 | 1F4CVL | Arch'l | 3 | MB |
| 1F5-FNS-B02-345 |  | B02 . AREA-3 -Raised Flooring | 6.25d | 2019-07-15 | 2019-07-20 | 1F5-FNS-B02-340 | 97.25d | 0d | Skilled Labour [171.6 h]; Unskilled Labour [57.2 h] | 17.44 | 1F4CVL | Arch'l | 3 | MB |
| 1F5-FNS-B02-350 |  | B02 . AREA-3 -Install Ceiling | 10d | 2019-07-21 | 2019-07-29 | 1F5-FNS-B02-345 | 117.75d | 0d | Unskilled Labour [171.6 h]; Skilled Labour [228.8 h] | 30.52 | 1F4CVL | Arch'l | 3 | MB |
| 1F5-FNS-B02-360 |  | B02 . AREA-3 -Install Floor Tiles | 7.5d | 2019-07-30 | 2019-08-05 | 1F5-FNS-B02-350 | 117.75d | 80.25d | Skilled Labour [257.4 h]; Unskilled Labour [128.7 h] | 29.43 | 1F4CVL | Arch'l | 3 | MB |
| 1F5-FNS-B02-370 |  | B02 . AREA-3 -Ceiling Final Painting | 7.5d | 2019-10-24 | 2019-10-31 | MR520, MR570, 1F5-FNS-B02-360 | 37.5d | 0d | Skilled Labour [214.5 h]; Unskilled Labour [128.7 h] | 26.16 | 1F4CVL | Arch'l | 3 | MB |
| 1F5-FNS-B02-380 |  | B02 . AREA-3 -Walls Final Painting | 7.5d | 2019-10-31 | 2019-11-07 | MR520, 1F5-FNS-B02-370, MR570 | 37.5d | 0d | Unskilled Labour [128.7 h]; Skilled Labour [214.5 h] | 26.16 | 1F4CVL | Arch'l | 3 | MB |
| 1F5-FNS-B02-390 |  | B02 . AREA-3 -Floor Epoxy Painting | 6.25d | 2019-11-07 | 2019-11-13 | 1F5-FNS-B02-370, 1F5-FNS-B02-380 | 49.5d | 0d | Skilled Labour [143 h]; Unskilled Labour [143 h] | 21.8 | 1F4CVL | Arch'l | 3 | MB |
| 1F5-FNS-B02-400 |  | B02 . AREA-3 -Install Door Hardware/Accessories | 3.75d | 2019-11-13 | 2019-11-17 | 1F5-FNS-B02-390, 1F5-FNS-B02-270, LOE-SUM2-180 FF | 49.5d | 8.75d | Skilled Labour [57.2 h]; Unskilled Labour [57.2 h] | 8.72 | 1F4CVL | Arch'l | 3 | MB |
|  | 4 | **B02 . AREA-2** |  | 2019-06-12 | 2019-11-28 |  |  |  |  |  |  |  |  |  |
|  | 4 | **BOH / FOH** |  | 2019-06-12 | 2019-11-28 |  |  |  |  |  |  |  |  |  |
| 1F5-FNS-B02-410 |  | B02 . AREA-2 -Block Masonry | 15d | 2019-06-12 | 2019-06-25 | 1F5-FNS-B02-280, C1C1111F5N2070 | -0.5d | 0d | Unskilled Labour [429 h]; Skilled Labour [686.4 h] | 85 | 1F4CVL | Arch'l | 2 | MB |
| 1F5-FNS-B02-420 |  | B02 . AREA-2 -Interior Plaster & Rendering | 12.5d | 2019-06-18 | 2019-06-29 | 1F5-FNS-B02-410 FF+3.75d | 26d | 0d | Unskilled Labour [257.4 h]; Skilled Labour [429 h] | 52.31 | 1F4CVL | Arch'l | 2 | MB |
| 1F5-FNS-B02-430 |  | B02 . AREA-2 -Gypsum Partition and Panel | 7.5d | 2019-06-30 | 2019-07-06 | 1F5-FNS-B02-420 | 26d | 0d | Skilled Labour [257.4 h]; Unskilled Labour [85.8 h] | 26.16 |  | Arch'l | 2 | MB |
| 1F5-FNS-B02-440 |  | B02 . AREA-2 -Ceiling Painting 1st Coat | 6.25d | 2019-07-07 | 2019-07-11 | 1F5-FNS-B02-410, 1F5-FNS-B02-430 | 26d | 0d | Skilled Labour [178.75 h]; Unskilled Labour [143 h] | 24.52 | 1F4CVL | Arch'l | 2 | MB |
| 1F5-FNS-B02-460 |  | B02 . AREA-2 -Walls Painting 1st Coat | 7.5d | 2019-07-13 | 2019-07-18 | 1F5-FNS-B02-440, 1F5-FNS-B02-420 FS+2.5d | 26d | 0d | Skilled Labour [214.5 h]; Unskilled Labour [214.5 h] | 32.7 | 1F4CVL | Arch'l | 2 | MB |
| 1F5-FNS-B02-470 |  | B02 . AREA-2 -Floor Concreted Screeding | 7.5d | 2019-07-20 | 2019-07-25 | 1F5-FNS-B02-460 | 26d | 0d | Unskilled Labour [171.6 h]; Skilled Labour [171.6 h] | 26.16 | 1F4CVL | Arch'l | 2 | MB |
| 1F5-FNS-B02-475 |  | B02 . AREA-2 -Raised Flooring | 6.25d | 2019-07-27 | 2019-07-31 | 1F5-FNS-B02-345, 1F5-FNS-B02-470 | 91d | 0d | Skilled Labour [171.6 h]; Unskilled Labour [57.2 h] | 17.44 | 1F4CVL | Arch'l | 2 | MB |
| 1F5-FNS-B02-480 |  | B02 . AREA-2 -Install Ceiling | 10d | 2019-08-01 | 2019-08-13 | 1F5-FNS-B02-475, CM090 FF | 106.25d | 0d | Unskilled Labour [171.6 h]; Skilled Labour [228.8 h] | 30.52 | 1F4CVL | Arch'l | 2 | MB |
| 1F5-FNS-B02-490 |  | B02 . AREA-2 -Install Floor Tiles | 7.5d | 2019-08-14 | 2019-08-20 | 1F5-FNS-B02-480 | 106.25d | 80.25d | Skilled Labour [257.4 h]; Unskilled Labour [128.7 h] | 29.43 | 1F4CVL | Arch'l | 2 | MB |
| 1F5-FNS-B02-5.. |  | B02 . AREA-2 -Ceiling Final Painting | 7.5d | 2019-11-05 | 2019-11-12 | MR580, MR530, 1F5-FNS-B02-490 | 26d | 0d | Skilled Labour [214.5 h]; Unskilled Labour [128.7 h] | 26.16 | 1F4CVL | Arch'l | 2 | MB |
| 1F5-FNS-B02-510 |  | B02 . AREA-2 -Walls Final Painting | 7.5d | 2019-11-12 | 2019-11-19 | MR580, 1F5-FNS-B02-380, MR530, 1F5-FNS-B02-5.. | 32.5d | 0d | Unskilled Labour [128.7 h]; Skilled Labour [214.5 h] | 26.16 | 1F4CVL | Arch'l | 2 | MB |
| 1F5-FNS-B02-520 |  | B02 . AREA-2 -Floor Epoxy Painting | 6.25d | 2019-11-19 | 2019-11-25 | 1F5-FNS-B02-510 | 40.75d | 0d | Skilled Labour [143 h]; Unskilled Labour [143 h] | 21.8 | 1F4CVL | Arch'l | 2 | MB |
| 1F5-FNS-B02-530 |  | B02 . AREA-2 -Install Door Hardware/Accessories | 3.75d | 2019-11-25 | 2019-11-28 | 1F5-FNS-B02-520, 1F5-FNS-B02-400 | 40.75d | 13.75d | Skilled Labour [57.2 h]; Unskilled Labour [57.2 h] | 8.72 | 1F4CVL | Arch'l | 2 | MB |

| ID | WBS | Activity | Type | Duration | Start | Finish | Predecessors | Total float | Free float | Calendar | Resources | Cost | 1F4 PROJECT | Discipline | AREA | LOCATION |
| --- | --- | --- | --- | --- | --- | --- | --- | --- | --- | --- | --- | --- | --- | --- | --- | --- |
|  | 5 | **B02 . AREA-1** |  |  | 2019-06-26 | 2019-12-15 |  |  |  |  |  |  |  |  |  |  |
|  | 4 | **BOH / FOH** |  |  | 2019-06-26 | 2019-12-15 |  |  |  |  |  |  |  |  |  |  |
| 1F5-FNS-B02-540 |  | B02 . AREA-1 -Block Masonry |  | 15d | 2019-06-26 | 2019-07-09 | C1C1111F5N2030 FS+7.5d, 1F5-FNS-B02-410, 1F5-ARDWG910, 1F5-FNS-B02-670 FF, C1C1111F5S1780 | -0.5d | 0d |  | Unskilled Labour [429 h]; Skilled Labour [686.4 h] | 85 | 1F4CVL | Arch'l | 1 | MB |
| 1F5-FNS-B02-550 |  | B02 . AREA-1 -Interior Plaster & Rendering |  | 12.5d | 2019-07-04 | 2019-07-15 | 1F5-ARDWG920, 1F5-FNS-B02-680 FF, 1F5-FNS-B02-540 FF+6.25d | -0.5d | 0d |  | Skilled Labour [429 h]; Unskilled Labour [257.4 h] | 52.31 | 1F4CVL | Arch'l | 1 | MB |
| 1F5-FNS-B02-560 |  | B02 . AREA-1 -Gypsum Partition and Panel |  | 7.5d | 2019-07-16 | 2019-07-22 | 1F5-FNS-B02-550, 1F5-ARDWG950 | -0.5d | 0d |  | Skilled Labour [257.4 h]; Unskilled Labour [85.8 h] | 26.16 |  | Arch'l | 1 | MB |
| 1F5-FNS-B02-570 |  | B02 . AREA-1 -Ceiling Painting 1st Coat |  | 6.25d | 2019-07-23 | 2019-07-28 | 1F5-ARDWG930, 1F5-FNS-B02-540, 1F5-FNS-B02-560 | -0.5d | 0d |  | Skilled Labour [178.75 h]; Unskilled Labour [143 h] | 24.52 | 1F4CVL | Arch'l | 1 | MB |
| 1F5-FNS-B02-590 |  | B02 . AREA-1 -Walls Painting 1st Coat |  | 7.5d | 2019-07-29 | 2019-08-04 | 1F5-ARDWG960, 1F5-FNS-B02-570, 1F5-FNS-B02-690 FF | -0.5d | 0d |  | Unskilled Labour [214.5 h]; Skilled Labour [214.5 h] | 32.7 | 1F4CVL | Arch'l | 1 | MB |
| 1F5-FNS-B02-600 |  | B02 . AREA-1 -Floor Concreted Screeding |  | 7.5d | 2019-08-05 | 2019-08-14 | 1F5-FNS-B02-590, 1F5-FNS-B02-700 FF, C1C1111F5N2140 | -0.5d | 0d |  | Unskilled Labour [171.6 h]; Skilled Labour [171.6 h] | 26.16 | 1F4CVL | Arch'l | 1 | MB |
| 1F5-FNS-B02-605 |  | B02 . AREA-1 -Raised Flooring |  | 6.25d | 2019-08-15 | 2019-08-20 | 1F5-ARDWG940, 1F5-FNS-B02-600, 1F5-FNS-B02-475 | 79.75d | 0d |  | Skilled Labour [171.6 h]; Unskilled Labour [57.2 h] | 17.44 | 1F4CVL | Arch'l | 1 | MB |
| 1F5-FNS-B02-610 |  | B02 . AREA-1 -Install Ceiling |  | 10d | 2019-08-21 | 2019-08-29 | 1F5-FNS-B02-605 | 79.75d | 0d |  | Unskilled Labour [171.6 h]; Skilled Labour [228.8 h] | 30.52 | 1F4CVL | Arch'l | 1 | MB |
| 1F5-FNS-B02-620 |  | B02 . AREA-1 -Install Floor Tiles |  | 7.5d | 2019-08-31 | 2019-09-05 | 1F5-FNS-B02-610 | 79.75d | 80.25d |  | Skilled Labour [257.4 h]; Unskilled Labour [128.7 h] | 29.43 | 1F4CVL | Arch'l | 1 | MB |
| 1F5-FNS-B02-630 |  | B02 . AREA-1 -Ceiling Final Painting |  | 7.5d | 2019-11-21 | 2019-11-28 | MR590, MR540, 1F5-FNS-B02-620 | -0.5d | 0d |  | Skilled Labour [214.5 h]; Unskilled Labour [128.7 h] | 26.16 | 1F4CVL | Arch'l | 1 | MB |
| 1F5-FNS-B02-640 |  | B02 . AREA-1 -Walls Final Painting |  | 7.5d | 2019-11-28 | 2019-12-05 | MR590, 1F5-FNS-B02-510, MR540, 1F5-FNS-B02-630 | 27d | 0d |  | Unskilled Labour [128.7 h]; Skilled Labour [214.5 h] | 26.16 | 1F4CVL | Arch'l | 1 | MB |
| 1F5-FNS-B02-650 |  | B02 . AREA-1 -Floor Epoxy Painting |  | 6.25d | 2019-12-05 | 2019-12-11 | 1F5-FNS-B02-710 FF, 1F5-FNS-B02-630, 1F5-FNS-B02-640 | 27d | 0d |  | Skilled Labour [143 h]; Unskilled Labour [143 h] | 21.8 | 1F4CVL | Arch'l | 1 | MB |
| 1F5-FNS-B02-660 |  | B02 . AREA-1 -Install Door Hardware/Accessories |  | 3.75d | 2019-12-11 | 2019-12-15 | 1F5-FNS-B02-530, 1F5-FNS-B02-650, 1F5-ARDWG970, LOE-SUM2-190 FF | 27d | 0d |  | Skilled Labour [57.2 h]; Unskilled Labour [57.2 h] | 8.72 | 1F4CVL | Arch'l | 1 | MB |
|  | 11 | **LOE Commodities ARCHL - B02 . Main Box . AREA-5 to AREA-1** |  |  | 2019-04-01 | 2019-12-11 |  |  |  |  |  |  |  |  |  |  |
| 1F5-FNS-B02-670 |  | LOE Archl - B02 . Main Box . AREA-5 to AREA-1 - Blockworks | level of effort | 103.75d | 2019-04-01 | 2019-07-09 | 1F5-FNS-B02-010 SS | -0.5d | 0d |  | Block Work [1384.02 Square Meter] |  |  | Arch'l | 5 | MB |
| 1F5-FNS-B02-680 |  | LOE Archl - B02 . Main Box . AREA-5 to AREA-1 - Plastering | level of effort | 101.25d | 2019-04-09 | 2019-07-15 | 1F5-FNS-B02-020 SS | -0.5d | 0d |  | Plaster Work [3079.65 Square Meter] |  |  | Arch'l | 5 | MB |
| 1F5-FNS-B02-690 |  | LOE Archl - B02 . Main Box . AREA-5 to AREA-1 - Painting | level of effort | 102.5d | 2019-04-28 | 2019-08-04 | 1F5-FNS-B02-040 SS | -0.5d | 0d |  | Painting [2310 Square Meter] |  |  | Arch'l | 5 | MB |
| 1F5-FNS-B02-700 |  | LOE Archl - B02 . Main Box . AREA-5 to AREA-1 - Screed | level of effort | 96.25d | 2019-05-11 | 2019-08-14 | 1F5-FNS-B02-070 SS | -0.5d | 0d |  | Screed Work [900 Square Meter] |  |  | Arch'l | 5 | MB |
| 1F5-FNS-B02-710 |  | LOE Archl - B02 . Main Box . AREA-5 to AREA-1 - Final Painting | level of effort | 110d | 2019-08-29 | 2019-12-11 | 1F5-FNS-B02-100 SS | 27d | 0d |  | Painting [770 Square Meter] |  |  | Arch'l | 5 | MB |
|  | 2 | **ARCHL WORKS at ENTRANCES** |  |  | 2019-02-06 | 2019-10-23 |  |  |  |  |  |  |  |  |  |  |
|  | 1 | **Archl Works at North East Entrance (NEE)** |  |  | 2019-02-06 | 2019-07-09 |  |  |  |  |  |  |  |  |  |  |
| LOE-SUM2-200 |  | NEE - Archl Works | level of effort | 165d | 2019-02-06 | 2019-07-09 | 1F5-FNS-NEE-010 SS | 205d | 0d | Saudi |  |  |  | Arch'l |  |  |

| ID | WBS | Activity | Duration | Start | Finish | Predecessors | Total float | Free float | Resources | Cost | 1F4 PROJECT | Discipline | LOCATION |
| --- | --- | --- | --- | --- | --- | --- | --- | --- | --- | --- | --- | --- | --- |
|  | 1 | **NEE . CONCOURSE LEVEL (B03, incl below)** |  | 2019-02-06 | 2019-05-14 |  |  |  |  |  |  |  |  |
| 1F5-FNS-NEE-010 |  | B03 . NEE -Block Masonry | 12.5d | 2019-02-06 | 2019-02-17 | C1C1111F5NEE-190 FS+32.5d | 97.25d | 0d | Unskilled Labour [286 h]; Skilled Labour [572 h] | 65.39 | 1F4CVL | Arch'l | NEE |
| 1F5-FNS-NEE-020 |  | B03 . NEE -Interior Plaster & Rendering | 12.5d | 2019-02-18 | 2019-02-28 | 1F5-FNS-NEE-010 | 97.25d | 0d | Skilled Labour [429 h]; Unskilled Labour [257.4 h] | 52.31 | 1F4CVL | Arch'l | NEE |
| 1F5-FNS-NEE-030 |  | B03 . NEE -Gypsum Partition and Panel | 10d | 2019-03-02 | 2019-03-10 | C1C1111F5NEE-3330, 1F5-FNS-NEE-020 | 97.25d | 0d | Skilled Labour [257.4 h]; Unskilled Labour [85.8 h] | 26.16 |  | Arch'l | NEE |
| 1F5-FNS-NEE-040 |  | B03 . NEE -Ceiling Painting 1st Coat | 6.25d | 2019-03-11 | 2019-03-16 | 1F5-FNS-NEE-010, 1F5-FNS-NEE-030 | 97.25d | 0d | Skilled Labour [178.75 h]; Unskilled Labour [143 h] | 24.52 | 1F4CVL | Arch'l | NEE |
| 1F5-FNS-NEE-050 |  | B03 . NEE -Walls Painting 1st Coat | 7.5d | 2019-03-17 | 2019-03-23 | 1F5-FNS-NEE-020 FS+2.5d, 1F5-FNS-NEE-040 | 97.25d | 0d | Skilled Labour [214.5 h]; Unskilled Labour [214.5 h] | 32.7 | 1F4CVL | Arch'l | NEE |
| 1F5-FNS-NEE-060 |  | B03 . NEE -Floor Concreted Screeding | 7.5d | 2019-03-24 | 2019-03-30 | 1F5-FNS-NEE-050 | 97.25d | 0d | Unskilled Labour [171.6 h]; Skilled Labour [171.6 h] | 26.16 | 1F4CVL | Arch'l | NEE |
| 1F5-FNS-NEE-070 |  | B03 . NEE -Raised Flooring | 6.25d | 2019-03-31 | 2019-04-04 | 1F5-FNS-NEE-060 | 256d | 0d | Skilled Labour [214.5 h]; Unskilled Labour [143 h] | 27.25 | 1F4CVL | Arch'l | NEE |
| 1F5-FNS-NEE-080 |  | B03 . NEE -Install Ceiling | 10d | 2019-04-06 | 2019-04-14 | 1F5-FNS-NEE-040, 1F5-FNS-NEE-070, 1F5-FNS-NEE-050 | 256d | 0d | Unskilled Labour [171.6 h]; Skilled Labour [228.8 h] | 30.52 | 1F4CVL | Arch'l | NEE |
| 1F5-FNS-NEE-090 |  | B03 . NEE -Install Floor Tiles | 7.5d | 2019-04-15 | 2019-04-21 | 1F5-FNS-NEE-080 | 256d | 0d | Skilled Labour [257.4 h]; Unskilled Labour [128.7 h] | 29.43 | 1F4CVL | Arch'l | NEE |
| 1F5-FNS-NEE-100 |  | B03 . NEE -Ceiling Final Painting | 7.5d | 2019-04-22 | 2019-04-28 | 1F5-FNS-NEE-040, 1F5-FNS-NEE-090 | 256d | 0d | Skilled Labour [214.5 h]; Unskilled Labour [128.7 h] | 26.16 | 1F4CVL | Arch'l | NEE |
| 1F5-FNS-NEE-110 |  | B03 . NEE -Walls Final Painting | 7.5d | 2019-04-29 | 2019-05-05 | 1F5-FNS-NEE-100 | 256d | 0d | Unskilled Labour [128.7 h]; Skilled Labour [214.5 h] | 26.16 | 1F4CVL | Arch'l | NEE |
| 1F5-FNS-NEE-120 |  | B03 . NEE -Floor Epoxy Painting | 6.25d | 2019-05-06 | 2019-05-11 | 1F5-FNS-NEE-060, 1F5-FNS-NEE-100, 1F5-FNS-NEE-110 | 256d | 0d | Skilled Labour [214.5 h]; Unskilled Labour [143 h] | 27.25 | 1F4CVL | Arch'l | NEE |
| 1F5-FNS-NEE-130 |  | B03 . NEE -Install Door Hardware/Accessories | 3.75d | 2019-05-12 | 2019-05-14 | 1F5-FNS-NEE-120, 1F5-FNS-NEE-090 FF | 256d | 56.25d | Skilled Labour [85.8 h]; Unskilled Labour [57.2 h] | 10.9 | 1F4CVL | Arch'l | NEE |
|  | 2 | **NEE . TV LOUVER LEVEL (B02, incl above)** |  | 2019-03-31 | 2019-07-09 |  |  |  |  |  |  |  |  |
| 1F5-FNS-NEE-140 |  | B02 . NEE -Block Masonry | 12.5d | 2019-03-31 | 2019-04-10 | 1F5-FNS-NEE-300 FF, 1F5-FNS-NEE-020, 1F5-FNS-NEE-060, C1C1111F5NEE-260 FS+32.5d | 97.25d | 0d | Unskilled Labour [286 h]; Skilled Labour [572 h] | 65.39 | 1F4CVL | Arch'l | NEE |
| 1F5-FNS-NEE-150 |  | B02 . NEE -Interior Plaster & Rendering | 12.5d | 2019-04-11 | 2019-04-22 | 1F5-FNS-NEE-310 FF, 1F5-FNS-NEE-140 | 97.25d | 0d | Skilled Labour [429 h]; Unskilled Labour [257.4 h] | 52.31 | 1F4CVL | Arch'l | NEE |
| 1F5-FNS-NEE-160 |  | B02 . NEE -Gypsum Partition and Panel | 10d | 2019-04-23 | 2019-05-01 | 1F5-FNS-NEE-150 | 97.25d | 0d | Unskilled Labour [85.8 h]; Skilled Labour [257.4 h] | 26.16 |  | Arch'l | NEE |
| 1F5-FNS-NEE-170 |  | B02 . NEE -Ceiling Painting 1st Coat | 6.25d | 2019-05-02 | 2019-05-07 | 1F5-FNS-NEE-160, 1F5-FNS-NEE-140 | 97.25d | 0d | Skilled Labour [178.75 h]; Unskilled Labour [143 h] | 24.52 | 1F4CVL | Arch'l | NEE |
| 1F5-FNS-NEE-180 |  | B02 . NEE -Walls Painting 1st Coat | 7.5d | 2019-05-08 | 2019-05-14 | 1F5-FNS-NEE-150 FS+2.5d, 1F5-FNS-NEE-330 FF, 1F5-FNS-NEE-170 | 97.25d | 0d | Skilled Labour [214.5 h]; Unskilled Labour [214.5 h] | 32.7 | 1F4CVL | Arch'l | NEE |
| 1F5-FNS-NEE-190 |  | B02 . NEE -Floor Concreted Screeding | 7.5d | 2019-05-15 | 2019-05-21 | 1F5-FNS-NEE-180, 1F5-FNS-NEE-320 FF | 97.25d | 0d | Unskilled Labour [171.6 h]; Skilled Labour [171.6 h] | 26.16 | 1F4CVL | Arch'l | NEE |
| 1F5-FNS-NEE-200 |  | B02 . NEE -Raised Flooring | 6.25d | 2019-05-22 | 2019-05-27 | 1F5-FNS-NEE-190 | 199.75d | 0d | Skilled Labour [214.5 h]; Unskilled Labour [143 h] | 27.25 | 1F4CVL | Arch'l | NEE |
| 1F5-FNS-NEE-210 |  | B02 . NEE -Install Ceiling | 10d | 2019-05-28 | 2019-06-09 | 1F5-FNS-NEE-180, 1F5-FNS-NEE-200 | 199.75d | 0d | Unskilled Labour [171.6 h]; Skilled Labour [228.8 h] | 30.52 | 1F4CVL | Arch'l | NEE |
| 1F5-FNS-NEE-220 |  | B02 . NEE -Install Floor Tiles | 7.5d | 2019-06-10 | 2019-06-16 | 1F5-FNS-NEE-210 | 199.75d | 0d | Skilled Labour [257.4 h]; Unskilled Labour [128.7 h] | 29.43 | 1F4CVL | Arch'l | NEE |
| 1F5-FNS-NEE-230 |  | B02 . NEE -Ceiling Final Painting | 7.5d | 2019-06-17 | 2019-06-23 | 1F5-FNS-NEE-220 | 199.75d | 0d | Skilled Labour [214.5 h]; Unskilled Labour [128.7 h] | 26.16 | 1F4CVL | Arch'l | NEE |
| 1F5-FNS-NEE-240 |  | B02 . NEE -Walls Final Painting | 7.5d | 2019-06-24 | 2019-06-30 | 1F5-FNS-NEE-230, 1F5-FNS-NEE-210 FF | 199.75d | 0d | Unskilled Labour [128.7 h]; Skilled Labour [214.5 h] | 26.16 | 1F4CVL | Arch'l | NEE |
| 1F5-FNS-NEE-250 |  | B02 . NEE -Floor Epoxy Painting | 6.25d | 2019-07-01 | 2019-07-06 | 1F5-FNS-NEE-340 FF, 1F5-FNS-NEE-240, 1F5-FNS-NEE-230 | 199.75d | 0d | Skilled Labour [214.5 h]; Unskilled Labour [143 h] | 27.25 | 1F4CVL | Arch'l | NEE |
| 1F5-FNS-NEE-260 |  | B02 . NEE -Install Door Hardware/Accessories | 3.75d | 2019-07-07 | 2019-07-09 | 1F5-FNS-NEE-130 FF, 1F5-FNS-NEE-250, LOE-SUM2-200 FF | 199.75d | 57.5d | Skilled Labour [85.8 h]; Unskilled Labour [57.2 h] | 10.9 | 1F4CVL | Arch'l | NEE |

| ID | WBS | Activity | Type | Duration | Start | Finish | Predecessors | Total float | Free float | Calendar | Resources | Cost | Discipline | LOCATION | 1F4 PROJECT |
| --- | --- | --- | --- | --- | --- | --- | --- | --- | --- | --- | --- | --- | --- | --- | --- |
|  | 11 | **LOE Commodities Archl NEE ( B01 to B03)** |  |  | 2019-02-06 | 2019-07-06 |  |  |  |  |  |  |  |  |  |
| 1F5-FNS-NEE-300 |  | LOE Commodities Archl NEE ( B01 to B03) - Blockworks | level of effort | 68.75d | 2019-02-06 | 2019-04-10 | 1F5-FNS-NEE-010 SS | 97.25d | 0d |  | Block Work [592 Square Meter] |  | Arch'l | NEE |  |
| 1F5-FNS-NEE-310 |  | LOE Commodities Archl NEE ( B01 to B03) - Plastering | level of effort | 68.75d | 2019-02-18 | 2019-04-22 | 1F5-FNS-NEE-020 SS | 97.25d | 0d |  | Plaster Work [1316 Square Meter] |  | Arch'l | NEE |  |
| 1F5-FNS-NEE-330 |  | LOE Commodities Archl NEE ( B01 to B03) - Painting | level of effort | 70d | 2019-03-11 | 2019-05-14 | 1F5-FNS-NEE-040 SS | 97.25d | 0d |  | Painting [975 Square Meter] |  | Arch'l | NEE |  |
| 1F5-FNS-NEE-320 |  | LOE Commodities Archl NEE ( B01 to B03) - Screed | level of effort | 63.75d | 2019-03-24 | 2019-05-21 | 1F5-FNS-NEE-060 SS | 97.25d | 0d |  | Screed Work [241 Square Meter] |  | Arch'l | NEE |  |
| 1F5-FNS-NEE-340 |  | LOE Commodities Archl NEE ( B01 to B03) - Final Painting | level of effort | 77.5d | 2019-04-22 | 2019-07-06 | 1F5-FNS-NEE-100 SS | 199.75d | 0d |  | Painting [325 Square Meter] |  | Arch'l | NEE |  |
|  | 2 | **Archl Works at North West Entrance (NWE)** |  |  | 2019-05-22 | 2019-10-23 |  |  |  |  |  |  |  |  |  |
| LOE-SUM2-210 |  | NWE - Archl Works | level of effort | 165.25d | 2019-05-22 | 2019-10-23 | 1F5-FNS-NWE-010 SS | 96d | 0d | Saudi |  |  | Arch'l |  |  |
|  | 1 | **NWE . CONCOURSE LEVEL (B03, incl below)** |  |  | 2019-05-22 | 2019-09-04 |  |  |  |  |  |  |  |  |  |
| 1F5-FNS-NWE-010 |  | B03 . NWE -Block Masonry |  | 12.5d | 2019-05-22 | 2019-06-02 | C1C1111F5NWE-330, C1C1111F5NWE-190 FS+15d, C1C1111F5NWE-300, 1F5-FNS-NEE-190 | 97.25d | 0d |  | Unskilled Labour [286 h]; Skilled Labour [572 h] | 65.39 | Arch'l | NWE | 1F4CVL |
| 1F5-FNS-NWE-020 |  | B03 . NWE -Interior Plaster & Rendering |  | 12.5d | 2019-06-03 | 2019-06-17 | 1F5-FNS-NWE-010 | 97.25d | 1.25d |  | Skilled Labour [429 h]; Unskilled Labour [257.4 h] | 52.31 | Arch'l | NWE | 1F4CVL |
| 1F5-FNS-NWE-030 |  | B03 . NWE -Gypsum Partition and Panel |  | 10d | 2019-06-19 | 2019-06-27 | 1F5-SMW-120, 1F5-FNS-NWE-020 | 96d | 0d |  | Skilled Labour [257.4 h]; Unskilled Labour [85.8 h] | 26.16 | Arch'l | NWE |  |
| 1F5-FNS-NWE-040 |  | B03 . NWE -Ceiling Painting 1st Coat |  | 6.25d | 2019-06-29 | 2019-07-03 | 1F5-FNS-NWE-010, 1F5-FNS-NWE-030 | 96d | 0d |  | Skilled Labour [178.75 h]; Unskilled Labour [143 h] | 24.52 | Arch'l | NWE | 1F4CVL |
| 1F5-FNS-NWE-050 |  | B03 . NWE -Walls Painting 1st Coat |  | 7.5d | 2019-07-04 | 2019-07-10 | 1F5-FNS-NWE-020 FS+2.5d, 1F5-FNS-NWE-040 | 96d | 0d |  | Skilled Labour [214.5 h]; Unskilled Labour [214.5 h] | 32.7 | Arch'l | NWE | 1F4CVL |
| 1F5-FNS-NWE-060 |  | B03 . NWE -Floor Concreted Screeding |  | 7.5d | 2019-07-11 | 2019-07-17 | 1F5-FNS-NWE-050 | 96d | 0d |  | Unskilled Labour [171.6 h]; Skilled Labour [171.6 h] | 26.16 | Arch'l | NWE | 1F4CVL |
| 1F5-FNS-NWE-070 |  | B03 . NWE -Raised Flooring |  | 6.25d | 2019-07-18 | 2019-07-23 | 1F5-FNS-NWE-060 | 142.25d | 0d |  | Skilled Labour [214.5 h]; Unskilled Labour [143 h] | 27.25 | Arch'l | NWE | 1F4CVL |
| 1F5-FNS-NWE-080 |  | B03 . NWE -Install Ceiling |  | 10d | 2019-07-24 | 2019-08-01 | 1F5-FNS-NWE-070 | 142.25d | 0d |  | Unskilled Labour [171.6 h]; Skilled Labour [228.8 h] | 30.52 | Arch'l | NWE | 1F4CVL |
| 1F5-FNS-NWE-090 |  | B03 . NWE -Install Floor Tiles |  | 7.5d | 2019-08-03 | 2019-08-08 | 1F5-FNS-NWE-080 | 142.25d | 0d |  | Skilled Labour [257.4 h]; Unskilled Labour [128.7 h] | 29.43 | Arch'l | NWE | 1F4CVL |
| 1F5-FNS-NWE-095 |  | B03 . NWE -Ceiling Final Painting |  | 7.5d | 2019-08-13 | 2019-08-19 | 1F5-FNS-NWE-090 | 142.25d | 0d |  | Skilled Labour [214.5 h]; Unskilled Labour [128.7 h] | 26.16 | Arch'l | NWE | 1F4CVL |
| 1F5-FNS-NWE-100 |  | B03 . NWE -Walls Final Painting |  | 7.5d | 2019-08-20 | 2019-08-26 | 1F5-FNS-NWE-090, 1F5-FNS-NWE-095 | 142.25d | 0d |  | Unskilled Labour [128.7 h]; Skilled Labour [214.5 h] | 26.16 | Arch'l | NWE | 1F4CVL |
| 1F5-FNS-NWE-110 |  | B03 . NWE -Floor Epoxy Painting |  | 6.25d | 2019-08-27 | 2019-09-01 | 1F5-FNS-NWE-060, 1F5-FNS-NWE-100, 1F5-FNS-NWE-095 | 142.25d | 0d |  | Skilled Labour [214.5 h]; Unskilled Labour [143 h] | 27.25 | Arch'l | NWE | 1F4CVL |
| 1F5-FNS-NWE-130 |  | B03 . NWE -Install Door Hardware/Accessories |  | 3.75d | 2019-09-02 | 2019-09-04 | 1F5-FNS-NWE-110, 1F5-FNS-NWE-090 FF, 1F5-FNS-NEE-260 FF | 142.25d | 46.25d |  | Skilled Labour [85.8 h]; Unskilled Labour [57.2 h] | 10.9 | Arch'l | NWE | 1F4CVL |
|  | 2 | **NWE . TV LOUVER LEVEL (B02, incl above)** |  |  | 2019-07-18 | 2019-10-23 |  |  |  |  |  |  |  |  |  |
| 1F5-FNS-NWE-140 |  | B02 . NWE -Block Masonry |  | 12.5d | 2019-07-18 | 2019-07-29 | 1F5-FNS-NWE-300 FF, 1F5-FNS-NWE-060, 1F5-FNS-NWE-020, 1F5-SMW-120 | 96d | 0d |  | Unskilled Labour [286 h]; Skilled Labour [572 h] | 65.39 | Arch'l | NWE | 1F4CVL |
| 1F5-FNS-NWE-150 |  | B02 . NWE -Interior Plaster & Rendering |  | 12.5d | 2019-07-24 | 2019-08-04 | 1F5-FNS-NWE-310, 1F5-FNS-NWE-140 FF+6.25d | 96d | 0d |  | Skilled Labour [429 h]; Unskilled Labour [257.4 h] | 52.31 | Arch'l | NWE | 1F4CVL |
| 1F5-FNS-NWE-160 |  | B02 . NWE -Gypsum Partition and Panel |  | 10d | 2019-08-05 | 2019-08-17 | 1F5-FNS-NWE-150 | 96d | 0d |  | Skilled Labour [257.4 h]; Unskilled Labour [85.8 h] | 26.16 | Arch'l | NWE |  |
| 1F5-FNS-NWE-170 |  | B02 . NWE -Ceiling Painting 1st Coat |  | 6.25d | 2019-08-18 | 2019-08-22 | 1F5-FNS-NWE-160, 1F5-FNS-NWE-140 | 96d | 0d |  | Skilled Labour [178.75 h]; Unskilled Labour [143 h] | 24.52 | Arch'l | NWE | 1F4CVL |
| 1F5-FNS-NWE-180 |  | B02 . NWE -Walls Painting 1st Coat |  | 7.5d | 2019-08-24 | 2019-08-29 | 1F5-FNS-NWE-330 FF, 1F5-FNS-NWE-150 FS+2.5d, 1F5-FNS-NWE-170 | 96d | 0d |  | Skilled Labour [214.5 h]; Unskilled Labour [214.5 h] | 32.7 | Arch'l | NWE | 1F4CVL |
| 1F5-FNS-NWE-190 |  | B02 . NWE -Floor Concreted Screeding |  | 7.5d | 2019-08-31 | 2019-09-05 | 1F5-FNS-NWE-180, 1F5-FNS-NWE-320 FF | 96d | 0d |  | Unskilled Labour [171.6 h]; Skilled Labour [171.6 h] | 26.16 | Arch'l | NWE | 1F4CVL |
| 1F5-FNS-NWE-200 |  | B02 . NWE -Raised Flooring |  | 6.25d | 2019-09-07 | 2019-09-11 | 1F5-FNS-NWE-190 | 96d | 0d |  | Skilled Labour [214.5 h]; Unskilled Labour [143 h] | 27.25 | Arch'l | NWE | 1F4CVL |
| 1F5-FNS-NWE-210 |  | B02 . NWE -Install Ceiling |  | 10d | 2019-09-12 | 2019-09-21 | 1F5-FNS-NWE-200, 1F5-FNS-NWE-180 | 96d | 0d |  | Unskilled Labour [171.6 h]; Skilled Labour [228.8 h] | 30.52 | Arch'l | NWE | 1F4CVL |
| 1F5-FNS-NWE-220 |  | B02 . NWE -Install Floor Tiles |  | 7.5d | 2019-09-22 | 2019-09-30 | 1F5-FNS-NWE-210 | 96d | 0d |  | Skilled Labour [257.4 h]; Unskilled Labour [128.7 h] | 29.43 | Arch'l | NWE | 1F4CVL |
| 1F5-FNS-NWE-230 |  | B02 . NWE -Ceiling Final Painting |  | 7.5d | 2019-09-30 | 2019-10-07 | 1F5-FNS-NWE-220 | 96d | 0d |  | Skilled Labour [214.5 h]; Unskilled Labour [128.7 h] | 26.16 | Arch'l | NWE | 1F4CVL |
| 1F5-FNS-NWE-240 |  | B02 . NWE -Walls Final Painting |  | 7.5d | 2019-10-07 | 2019-10-14 | 1F5-FNS-NWE-230 | 96d | 0d |  | Unskilled Labour [128.7 h]; Skilled Labour [214.5 h] | 26.16 | Arch'l | NWE | 1F4CVL |
| 1F5-FNS-NWE-250 |  | B02 . NWE -Floor Epoxy Painting |  | 6.25d | 2019-10-14 | 2019-10-20 | 1F5-FNS-NWE-340 FF, 1F5-FNS-NWE-230, 1F5-FNS-NWE-240 | 96d | 0d |  | Skilled Labour [214.5 h]; Unskilled Labour [143 h] | 27.25 | Arch'l | NWE | 1F4CVL |
| 1F5-FNS-NWE-260 |  | B02 . NWE -Install Door Hardware/Accessories |  | 3.75d | 2019-10-20 | 2019-10-23 | 1F5-FNS-NWE-250, 1F5-FNS-NWE-130, LOE-SUM2-210 FF | 96d | 92.25d |  | Skilled Labour [85.8 h]; Unskilled Labour [57.2 h] | 10.9 | Arch'l | NWE | 1F4CVL |

| ID | WBS | Activity | Type | Duration | Start | Finish | Predecessors | Total float | Free float | Calendar | Resources | Cost | Discipline | LOCATION | 1F4 PROJECT |
| --- | --- | --- | --- | --- | --- | --- | --- | --- | --- | --- | --- | --- | --- | --- | --- |
|  | 11 | **LOE Commodities Archl NWE ( B01 to B03)** |  |  | 2019-05-22 | 2019-10-20 |  |  |  |  |  |  |  |  |  |
| 1F5-FNS-NWE-300 |  | LOE Commodities Archl NWE ( B01 to B03) - Blockworks | level of effort | 70d | 2019-05-22 | 2019-07-29 | 1F5-FNS-NWE-010 SS | 96d | 0d |  | Block Work [605 Square Meter] |  | Arch'l | NWE |  |
| 1F5-FNS-NWE-310 |  | LOE Commodities Archl NWE ( B01 to B03) - Plastering | level of effort | 51.25d | 2019-06-03 | 2019-07-23 | 1F5-FNS-NWE-020 SS | 96d | 0d |  | Plaster Work [1436.16 Square Meter] |  | Arch'l | NWE |  |
| 1F5-FNS-NWE-330 |  | LOE Commodities Archl NWE ( B01 to B03) - Painting | level of effort | 63.75d | 2019-06-29 | 2019-08-29 | 1F5-FNS-NWE-040 SS | 96d | 0d |  | Painting [1050 Square Meter] |  | Arch'l | NWE |  |
| 1F5-FNS-NWE-320 |  | LOE Commodities Archl NWE ( B01 to B03) - Screed | level of effort | 57.5d | 2019-07-11 | 2019-09-05 | 1F5-FNS-NWE-060 SS | 96d | 0d |  | Screed Work [241 Square Meter] |  | Arch'l | NWE |  |
| 1F5-FNS-NWE-340 |  | LOE Commodities Archl NWE ( B01 to B03) - Final Painting | level of effort | 71.25d | 2019-08-13 | 2019-10-20 | 1F5-FNS-NWE-095 SS | 96d | 0d |  | Painting [350 Square Meter] |  | Arch'l | NWE |  |
|  | 3 | **ARCHL WORKS at ACY** |  |  | 2019-04-23 | 2019-12-19 |  |  |  |  |  |  |  |  |  |
|  | 2 | **Archl Works at ACY-1** |  |  | 2019-04-23 | 2019-10-30 |  |  |  |  |  |  |  |  |  |
| LOE-SUM2-220 |  | ACY1 - Archl Works | level of effort | 204d | 2019-04-23 | 2019-10-30 | 1F5-FNS-ACY1-010 SS | 81d | 0d | Saudi |  |  | Arch'l |  |  |
|  | 1 | **ACY-1 . CONCOURSE LEVEL (B03, incl below)** |  |  | 2019-04-23 | 2019-08-28 |  |  |  |  |  |  |  |  |  |
| 1F5-FNS-ACY1-010 |  | B03 . ACY1 -Block Masonry |  | 12.5d | 2019-04-23 | 2019-05-04 | C1C1111F5AY1-130 FS+32.5d | 68.5d | 0d |  | Unskilled Labour [286 h]; Skilled Labour [572 h] | 65.39 | Arch'l | ACY1 | 1F4CVL |
| 1F5-FNS-ACY1-020 |  | B03 . ACY1 -Interior Plaster & Rendering |  | 12.5d | 2019-05-05 | 2019-05-15 | 1F5-FNS-ACY1-010 | 81d | 0d |  | Skilled Labour [429 h]; Unskilled Labour [257.4 h] | 52.31 | Arch'l | ACY1 | 1F4CVL |
| 1F5-FNS-ACY1-030 |  | B03 . ACY1 -Gypsum Partition and Panel |  | 10d | 2019-05-16 | 2019-05-25 | 1F5-FNS-ACY1-020 | 81d | 0d |  | Skilled Labour [257.4 h]; Unskilled Labour [85.8 h] | 26.16 | Arch'l | ACY1 |  |
| 1F5-FNS-ACY1-040 |  | B03 . ACY1 -Ceiling Painting 1st Coat |  | 10d | 2019-05-26 | 2019-06-03 | 1F5-FNS-ACY1-030 | 81d | 0d |  | Skilled Labour [178.75 h]; Unskilled Labour [143 h] | 24.52 | Arch'l | ACY1 | 1F4CVL |
| 1F5-FNS-ACY1-050 |  | B03 . ACY1 -Walls Painting 1st Coat |  | 10d | 2019-06-08 | 2019-06-16 | 1F5-FNS-ACY1-040 | 81d | 0d |  | Skilled Labour [214.5 h]; Unskilled Labour [214.5 h] | 32.7 | Arch'l | ACY1 | 1F4CVL |
| 1F5-FNS-ACY1-060 |  | B03 . ACY1 -Floor Concreted Screeding |  | 10d | 2019-06-17 | 2019-06-25 | C1C1111F5AY1-270, 1F5-FNS-ACY1-050 | 81d | 0d |  | Unskilled Labour [171.6 h]; Skilled Labour [171.6 h] | 26.16 | Arch'l | ACY1 | 1F4CVL |
| 1F5-FNS-ACY1-070 |  | B03 . ACY1 -Raised Flooring |  | 10d | 2019-06-26 | 2019-07-04 | 1F5-FNS-ACY1-060 | 141d | 0d |  | Skilled Labour [214.5 h]; Unskilled Labour [143 h] | 27.25 | Arch'l | ACY1 | 1F4CVL |
| 1F5-FNS-ACY1-080 |  | B03 . ACY1 -Install Ceiling |  | 10d | 2019-07-06 | 2019-07-14 | 1F5-FNS-ACY1-070 | 141d | 0d |  | Unskilled Labour [171.6 h]; Skilled Labour [228.8 h] | 30.52 | Arch'l | ACY1 | 1F4CVL |
| 1F5-FNS-ACY1-090 |  | B03 . ACY1 -Install Floor Tiles |  | 10d | 2019-07-15 | 2019-07-23 | 1F5-FNS-ACY1-080, 1F5-FNS-ACY1-070 | 141d | 0d |  | Skilled Labour [257.4 h]; Unskilled Labour [128.7 h] | 29.43 | Arch'l | ACY1 | 1F4CVL |
| 1F5-FNS-ACY1-110 |  | B03 . ACY1 -Ceiling Final Painting |  | 10d | 2019-07-24 | 2019-08-01 | 1F5-FNS-ACY1-090 | 141d | 0d |  | Skilled Labour [214.5 h]; Unskilled Labour [128.7 h] | 26.16 | Arch'l | ACY1 | 1F4CVL |
| 1F5-FNS-ACY1-120 |  | B03 . ACY1 -Walls Final Painting |  | 10d | 2019-08-03 | 2019-08-14 | 1F5-FNS-ACY1-110 | 141d | 0d |  | Unskilled Labour [128.7 h]; Skilled Labour [214.5 h] | 26.16 | Arch'l | ACY1 | 1F4CVL |
| 1F5-FNS-ACY1-130 |  | B03 . ACY1 -Floor Epoxy Painting |  | 10d | 2019-08-15 | 2019-08-24 | 1F5-FNS-ACY1-120, 1F5-FNS-ACY1-110 | 141d | 0d |  | Skilled Labour [214.5 h]; Unskilled Labour [143 h] | 27.25 | Arch'l | ACY1 | 1F4CVL |
| 1F5-FNS-ACY1-140 |  | B03 . ACY1 -Install Door Hardware/Accessories |  | 5d | 2019-08-25 | 2019-08-28 | 1F5-FNS-ACY1-130 | 141d | 60d |  | Skilled Labour [85.8 h]; Unskilled Labour [57.2 h] | 10.9 | Arch'l | ACY1 | 1F4CVL |
|  | 2 | **ACY-1 . TV LOUVER LEVEL (B02, incl above)** |  |  | 2019-06-26 | 2019-10-30 |  |  |  |  |  |  |  |  |  |
| 1F5-FNS-ACY1--150 |  | B02 . ACY1 -Block Masonry |  | 12.5d | 2019-06-26 | 2019-07-07 | 1F5-FNS-ACY1-060, 1F5-FNS-ACY1-300, 1F5-FNS-ACY1-010 | 81d | 0d |  | Unskilled Labour [286 h]; Skilled Labour [572 h] | 65.39 | Arch'l | ACY1 | 1F4CVL |
| 1F5-FNS-ACY1--160 |  | B02 . ACY1 -Interior Plaster & Rendering |  | 12.5d | 2019-07-08 | 2019-07-18 | 1F5-FNS-ACY1--150 | 81d | 0d |  | Skilled Labour [429 h]; Unskilled Labour [257.4 h] | 52.31 | Arch'l | ACY1 | 1F4CVL |
| 1F5-FNS-ACY1--170 |  | B02 . ACY1 -Gypsum Partition and Panel |  | 10d | 2019-07-20 | 2019-07-28 | 1F5-FNS-ACY1-310 FF, 1F5-FNS-ACY1--160 | 81d | 0d |  | Skilled Labour [257.4 h]; Unskilled Labour [85.8 h] | 26.16 | Arch'l | ACY1 |  |
| 1F5-FNS-ACY1--180 |  | B02 . ACY1 -Ceiling Painting 1st Coat |  | 10d | 2019-07-29 | 2019-08-06 | 1F5-FNS-ACY1--170 | 81d | 0d |  | Skilled Labour [178.75 h]; Unskilled Labour [143 h] | 24.52 | Arch'l | ACY1 | 1F4CVL |
| 1F5-FNS-ACY1--190 |  | B02 . ACY1 -Walls Painting 1st Coat |  | 10d | 2019-08-07 | 2019-08-19 | 1F5-FNS-ACY1-320 FF, 1F5-FNS-ACY1--160 FS+2.5d, 1F5-FNS-ACY1--180 | 81d | 0d |  | Skilled Labour [214.5 h]; Unskilled Labour [214.5 h] | 32.7 | Arch'l | ACY1 | 1F4CVL |
| 1F5-FNS-ACY1--200 |  | B02 . ACY1 -Floor Concreted Screeding |  | 10d | 2019-08-20 | 2019-08-28 | 1F5-FNS-ACY1-330 FF, 1F5-FNS-ACY1--190 | 81d | 0d |  | Unskilled Labour [171.6 h]; Skilled Labour [171.6 h] | 26.16 | Arch'l | ACY1 | 1F4CVL |
| 1F5-FNS-ACY1--210 |  | B02 . ACY1 -Raised Flooring |  | 10d | 2019-08-29 | 2019-09-07 | 1F5-FNS-ACY1--200 | 81d | 0d |  | Skilled Labour [214.5 h]; Unskilled Labour [143 h] | 27.25 | Arch'l | ACY1 | 1F4CVL |
| 1F5-FNS-ACY1--220 |  | B02 . ACY1 -Install Ceiling |  | 10d | 2019-09-08 | 2019-09-16 | 1F5-FNS-ACY1--190, 1F5-FNS-ACY1--210 | 81d | 0d |  | Unskilled Labour [171.6 h]; Skilled Labour [228.8 h] | 30.52 | Arch'l | ACY1 | 1F4CVL |
| 1F5-FNS-ACY1--230 |  | B02 . ACY1 -Install Floor Tiles |  | 10d | 2019-09-17 | 2019-09-28 | 1F5-FNS-ACY1--210, 1F5-FNS-ACY1--220 FF, 1F5-FNS-ACY1--220 | 81d | 0d |  | Skilled Labour [257.4 h]; Unskilled Labour [128.7 h] | 29.43 | Arch'l | ACY1 | 1F4CVL |
| 1F5-FNS-ACY1--240 |  | B02 . ACY1 -Ceiling Final Painting |  | 10d | 2019-09-28 | 2019-10-07 | 1F5-FNS-ACY1--230 | 81d | 0d |  | Skilled Labour [214.5 h]; Unskilled Labour [128.7 h] | 26.16 | Arch'l | ACY1 | 1F4CVL |
| 1F5-FNS-ACY1--250 |  | B02 . ACY1 -Walls Final Painting |  | 10d | 2019-10-07 | 2019-10-16 | 1F5-FNS-ACY1--240 | 81d | 0d |  | Unskilled Labour [128.7 h]; Skilled Labour [214.5 h] | 26.16 | Arch'l | ACY1 | 1F4CVL |
| 1F5-FNS-ACY1--260 |  | B02 . ACY1 -Floor Epoxy Painting |  | 10d | 2019-10-16 | 2019-10-26 | 1F5-FNS-ACY1--250, 1F5-FNS-ACY1-340 FF, 1F5-FNS-ACY1--240 | 81d | 0d |  | Skilled Labour [214.5 h]; Unskilled Labour [143 h] | 27.25 | Arch'l | ACY1 | 1F4CVL |
| 1F5-FNS-ACY1--270 |  | B02 . ACY1 -Install Door Hardware/Accessories |  | 5d | 2019-10-26 | 2019-10-30 | 1F5-FNS-ACY1-140, 1F5-FNS-ACY1--260, 1F5-FNS-ACY1--260 FF, LOE-SUM2-220 FF | 81d | 54d |  | Skilled Labour [85.8 h]; Unskilled Labour [57.2 h] | 10.9 | Arch'l | ACY1 | 1F4CVL |

| ID | WBS | Activity | Type | Duration | Start | Finish | Predecessors | Total float | Free float | Calendar | Resources | Cost | Discipline | LOCATION | 1F4 PROJECT |
| --- | --- | --- | --- | --- | --- | --- | --- | --- | --- | --- | --- | --- | --- | --- | --- |
|  | 11 | **LOE Commodities Archl ACY-1 ( B01 to B03)** |  |  | 2019-04-23 | 2019-10-26 |  |  |  |  |  |  |  |  |  |
| 1F5-FNS-ACY1-300 |  | LOE Commodities Archl ACY-1 ( B01 to B03) - Blockworks | level of effort | 65d | 2019-04-23 | 2019-06-25 | 1F5-FNS-ACY1-010 SS | 81d | 0d |  | Block Work [323 Square Meter] |  | Arch'l | ACY1 |  |
| 1F5-FNS-ACY1-310 |  | LOE Commodities Archl ACY-1 ( B01 to B03) - Plastering | level of effort | 87.5d | 2019-05-05 | 2019-07-28 | 1F5-FNS-ACY1-020 SS | 81d | 0d |  | Plaster Work [700 Square Meter] |  | Arch'l | ACY1 |  |
| 1F5-FNS-ACY1-320 |  | LOE Commodities Archl ACY-1 ( B01 to B03) - Painting | level of effort | 85d | 2019-05-26 | 2019-08-19 | 1F5-FNS-ACY1-040 SS | 81d | 0d |  | Painting [539 Square Meter] |  | Arch'l | ACY1 |  |
| 1F5-FNS-ACY1-330 |  | LOE Commodities Archl ACY-1 ( B01 to B03) - Screed | level of effort | 75d | 2019-06-17 | 2019-08-28 | 1F5-FNS-ACY1-060 SS | 81d | 0d |  | Screed Work [442 Square Meter] |  | Arch'l | ACY1 |  |
| 1F5-FNS-ACY1-340 |  | LOE Commodities Archl ACY-1 ( B01 to B03) - Final Painting | level of effort | 95d | 2019-07-24 | 2019-10-26 | 1F5-FNS-ACY1-110 SS | 81d | 0d |  | Painting [180 Square Meter] |  | Arch'l | ACY1 |  |
|  | 1 | **Archl Works at ACY-2** |  |  | 2019-05-05 | 2019-12-19 |  |  |  |  |  |  |  |  |  |
| LOE-SUM2-230 |  | ACY2 - Archl Works | level of effort | 245.5d | 2019-05-05 | 2019-12-19 | 1F5-FNS-ACY2-010 SS | 27d | 0d | Saudi |  |  | Arch'l |  |  |
|  | 1 | **ACY-2 . CONCOURSE LEVEL (B03, incl below)** |  |  | 2019-05-05 | 2019-09-09 |  |  |  |  |  |  |  |  |  |
| 1F5-FNS-ACY2-010 |  | B03 . ACY2 -Block Masonry |  | 12.5d | 2019-05-05 | 2019-05-15 | 1F5-FNS-ACY1-010, C1C1111F5AY2-130 FS+32.5d, C1C1111F5AY2-280 | 68.5d | 0d |  | Unskilled Labour [286 h]; Skilled Labour [572 h] | 65.39 | Arch'l | ACY2 | 1F4CVL |
| 1F5-FNS-ACY2-020 |  | B03 . ACY2 -Interior Plaster & Rendering |  | 12.5d | 2019-05-16 | 2019-05-27 | 1F5-FNS-ACY2-010 | 68.5d | 0d |  | Skilled Labour [429 h]; Unskilled Labour [257.4 h] | 52.31 | Arch'l | ACY2 | 1F4CVL |
| 1F5-FNS-ACY2-030 |  | B03 . ACY2 -Gypsum Partition and Panel |  | 10d | 2019-05-28 | 2019-06-09 | 1F5-FNS-ACY2-020, 1F5-SMW-070 | 68.5d | 0d |  | Skilled Labour [257.4 h]; Unskilled Labour [85.8 h] | 26.16 | Arch'l | ACY2 |  |
| 1F5-FNS-ACY2-040 |  | B03 . ACY2 -Ceiling Painting 1st Coat |  | 10d | 2019-06-10 | 2019-06-18 | 1F5-FNS-ACY2-010, 1F5-FNS-ACY2-030 | 68.5d | 0d |  | Skilled Labour [178.75 h]; Unskilled Labour [143 h] | 24.52 | Arch'l | ACY2 | 1F4CVL |
| 1F5-FNS-ACY2-050 |  | B03 . ACY2 -Walls Painting 1st Coat |  | 10d | 2019-06-19 | 2019-06-27 | 1F5-FNS-ACY2-040 | 68.5d | 0d |  | Skilled Labour [214.5 h]; Unskilled Labour [214.5 h] | 32.7 | Arch'l | ACY2 | 1F4CVL |
| 1F5-FNS-ACY2-060 |  | B03 . ACY2 -Floor Concreted Screeding |  | 10d | 2019-06-29 | 2019-07-07 | 1F5-FNS-ACY2-050 | 68.5d | 0d |  | Unskilled Labour [171.6 h]; Skilled Labour [171.6 h] | 26.16 | Arch'l | ACY2 | 1F4CVL |
| 1F5-FNS-ACY2-070 |  | B03 . ACY2 -Raised Flooring |  | 10d | 2019-07-08 | 2019-07-16 | 1F5-FNS-ACY2-060 | 128.5d | 0d |  | Skilled Labour [214.5 h]; Unskilled Labour [143 h] | 27.25 | Arch'l | ACY2 | 1F4CVL |
| 1F5-FNS-ACY2-080 |  | B03 . ACY2 -Install Ceiling |  | 10d | 2019-07-17 | 2019-07-25 | 1F5-FNS-ACY2-060, 1F5-FNS-ACY2-070 | 128.5d | 0d |  | Unskilled Labour [171.6 h]; Skilled Labour [228.8 h] | 30.52 | Arch'l | ACY2 | 1F4CVL |
| 1F5-FNS-ACY2-090 |  | B03 . ACY2 -Install Floor Tiles |  | 10d | 2019-07-27 | 2019-08-04 | 1F5-FNS-ACY2-080, 1F5-FNS-ACY2-070 | 128.5d | 0d |  | Skilled Labour [257.4 h]; Unskilled Labour [128.7 h] | 29.43 | Arch'l | ACY2 | 1F4CVL |
| 1F5-FNS-ACY2-100 |  | B03 . ACY2 -Ceiling Final Painting |  | 10d | 2019-08-05 | 2019-08-17 | 1F5-FNS-ACY2-090 | 128.5d | 0d |  | Skilled Labour [214.5 h]; Unskilled Labour [128.7 h] | 26.16 | Arch'l | ACY2 | 1F4CVL |
| 1F5-FNS-ACY2-110 |  | B03 . ACY2 -Walls Final Painting |  | 10d | 2019-08-18 | 2019-08-26 | 1F5-FNS-ACY2-100 | 128.5d | 0d |  | Unskilled Labour [128.7 h]; Skilled Labour [214.5 h] | 26.16 | Arch'l | ACY2 | 1F4CVL |
| 1F5-FNS-ACY2-120 |  | B03 . ACY2 -Floor Epoxy Painting |  | 10d | 2019-08-27 | 2019-09-04 | 1F5-FNS-ACY2-110, 1F5-FNS-ACY2-100 | 128.5d | 0d |  | Skilled Labour [214.5 h]; Unskilled Labour [143 h] | 27.25 | Arch'l | ACY2 | 1F4CVL |
| 1F5-FNS-ACY2-130 |  | B03 . ACY2 -Install Door Hardware/Accessories |  | 5d | 2019-09-05 | 2019-09-09 | 1F5-FNS-ACY2-120 | 128.5d | 101.5d |  | Skilled Labour [85.8 h]; Unskilled Labour [57.2 h] | 10.9 | Arch'l | ACY2 | 1F4CVL |
|  | 2 | **ACY-2 . TV LOUVER LEVEL (B02, incl above)** |  |  | 2019-07-08 | 2019-12-19 |  |  |  |  |  |  |  |  |  |
| 1F5-FNS-ACY2-140 |  | B02 . ACY2 -Block Masonry |  | 12.5d | 2019-07-08 | 2019-07-18 | 1F5-FNS-ACY2-060, 1F5-FNS-ACY2-300 FF, C1C1111F5AY1-200 FS+32.5d | 68.5d | 0d |  | Unskilled Labour [286 h]; Skilled Labour [572 h] | 65.39 | Arch'l | ACY2 | 1F4CVL |
| 1F5-FNS-ACY2-150 |  | B02 . ACY2 -Interior Plaster & Rendering |  | 12.5d | 2019-07-20 | 2019-07-30 | 1F5-FNS-ACY2-310 FF, 1F5-FNS-ACY2-140 | 68.5d | 0d |  | Skilled Labour [429 h]; Unskilled Labour [257.4 h] | 52.31 | Arch'l | ACY2 | 1F4CVL |
| 1F5-FNS-ACY2-160 |  | B02 . ACY2 -Gypsum Partition and Panel |  | 10d | 2019-07-31 | 2019-08-08 | 1F5-FNS-ACY2-150 | 68.5d | 0d |  | Skilled Labour [257.4 h]; Unskilled Labour [85.8 h] | 26.16 | Arch'l | ACY2 |  |
| 1F5-FNS-ACY2-170 |  | B02 . ACY2 -Ceiling Painting 1st Coat |  | 10d | 2019-08-13 | 2019-08-21 | 1F5-FNS-ACY2-160, 1F5-FNS-ACY2-140 | 68.5d | 0d |  | Skilled Labour [178.75 h]; Unskilled Labour [143 h] | 24.52 | Arch'l | ACY2 | 1F4CVL |
| 1F5-FNS-ACY2-180 |  | B02 . ACY2 -Walls Painting 1st Coat |  | 10d | 2019-08-22 | 2019-08-31 | 1F5-FNS-ACY2-150 FS+2.5d, 1F5-FNS-ACY2-170, 1F5-FNS-ACY2-320 FF | 68.5d | 0d |  | Skilled Labour [214.5 h]; Unskilled Labour [214.5 h] | 32.7 | Arch'l | ACY2 | 1F4CVL |
| 1F5-FNS-ACY2-190 |  | B02 . ACY2 -Floor Concreted Screeding |  | 10d | 2019-09-01 | 2019-09-09 | 1F5-FNS-ACY2-330 FF, 1F5-FNS-ACY2-180 | 68.5d | 0d |  | Unskilled Labour [171.6 h]; Skilled Labour [171.6 h] | 26.16 | Arch'l | ACY2 | 1F4CVL |
| 1F5-FNS-ACY2-200 |  | B02 . ACY2 -Raised Flooring |  | 10d | 2019-09-10 | 2019-09-18 | 1F5-FNS-ACY2-190 | 68.5d | 0d |  | Skilled Labour [214.5 h]; Unskilled Labour [143 h] | 27.25 | Arch'l | ACY2 | 1F4CVL |
| 1F5-FNS-ACY2-210 |  | B02 . ACY2 -Install Ceiling |  | 10d | 2019-09-19 | 2019-09-30 | 1F5-FNS-ACY2-180, 1F5-FNS-ACY2-200 | 68.5d | 0d |  | Unskilled Labour [171.6 h]; Skilled Labour [228.8 h] | 30.52 | Arch'l | ACY2 | 1F4CVL |
| 1F5-FNS-ACY2-220 |  | B02 . ACY2 -Install Floor Tiles |  | 10d | 2019-09-30 | 2019-10-09 | 1F5-FNS-ACY2-210, 1F5-FNS-ACY2-200 | 68.5d | 0d |  | Skilled Labour [257.4 h]; Unskilled Labour [128.7 h] | 29.43 | Arch'l | ACY2 | 1F4CVL |
| 1F5-FNS-ACY2-230 |  | B02 . ACY2 -Ceiling Final Painting |  | 10d | 2019-10-09 | 2019-10-19 | 1F5-FNS-ACY2-220 | 68.5d | 0d |  | Skilled Labour [214.5 h]; Unskilled Labour [128.7 h] | 26.16 | Arch'l | ACY2 | 1F4CVL |
| 1F5-FNS-ACY2-240 |  | B02 . ACY2 -Walls Final Painting |  | 10d | 2019-10-19 | 2019-10-28 | 1F5-FNS-ACY2-230 | 68.5d | 0d |  | Unskilled Labour [128.7 h]; Skilled Labour [214.5 h] | 26.16 | Arch'l | ACY2 | 1F4CVL |
| 1F5-FNS-ACY2-250 |  | B02 . ACY2 -Floor Epoxy Painting |  | 10d | 2019-10-28 | 2019-11-06 | 1F5-FNS-ACY2-340 FF, 1F5-FNS-ACY2-240, 1F5-FNS-ACY2-230 | 68.5d | 41.5d |  | Skilled Labour [214.5 h]; Unskilled Labour [143 h] | 27.25 | Arch'l | ACY2 | 1F4CVL |
| 1F5-FNS-ACY2-260 |  | B02 . ACY2 -Install Door Hardware/Accessories |  | 5d | 2019-12-15 | 2019-12-19 | 1F5-FNS-ACY1--270 FF, 1F5-FNS-B02-660, 1F5-FNS-B02-530, 1F5-FNS-ACY2-130, 1F5-FNS-ACY2-250, LOE-SUM2-230 FF | 27d | 23.25d |  | Skilled Labour [85.8 h]; Unskilled Labour [57.2 h] | 10.9 | Arch'l | ACY2 | 1F4CVL |

| ID | WBS | Activity | Type | Duration | Start | Finish | Predecessors | Total float | Free float | Calendar | Resources | Cost | Discipline | LOCATION | MSP Activity ID | MEP-Phase | AREA |
| --- | --- | --- | --- | --- | --- | --- | --- | --- | --- | --- | --- | --- | --- | --- | --- | --- | --- |
|  | 11 | **LOE Commodities Archl ACY-2 ( B01 to B03)** |  |  | 2019-05-05 | 2019-11-06 |  |  |  |  |  |  |  |  |  |  |  |
| 1F5-FNS-ACY2-300 |  | LOE Commodities Archl ACY-2 ( B01 to B03) - Blockworks | level of effort | 77.5d | 2019-05-05 | 2019-07-18 | 1F5-FNS-ACY2-010 SS | 68.5d | 0d |  | Block Work [322.71 Square Meter] |  | Arch'l | ACY2 |  |  |  |
| 1F5-FNS-ACY2-310 |  | LOE Commodities Archl ACY-2 ( B01 to B03) - Plastering | level of effort | 77.5d | 2019-05-16 | 2019-07-30 | 1F5-FNS-ACY2-020 SS | 68.5d | 0d |  | Plaster Work [700 Square Meter] |  | Arch'l | ACY2 |  |  |  |
| 1F5-FNS-ACY2-320 |  | LOE Commodities Archl ACY-2 ( B01 to B03) - Painting | level of effort | 85d | 2019-06-10 | 2019-08-31 | 1F5-FNS-ACY2-040 SS | 68.5d | 0d |  | Painting [539 Square Meter] |  | Arch'l | ACY2 |  |  |  |
| 1F5-FNS-ACY2-330 |  | LOE Commodities Archl ACY-2 ( B01 to B03) - Screed | level of effort | 75d | 2019-06-29 | 2019-09-09 | 1F5-FNS-ACY2-060 SS | 68.5d | 0d |  | Screed Work [483 Square Meter] |  | Arch'l | ACY2 |  |  |  |
| 1F5-FNS-ACY2-340 |  | LOE Commodities Archl ACY-2 ( B01 to B03) - Final Painting | level of effort | 95d | 2019-08-05 | 2019-11-06 | 1F5-FNS-ACY2-100 SS | 68.5d | 0d |  | Painting [180 Square Meter] |  | Arch'l | ACY2 |  |  |  |
|  | 1.4 | **MEP CONSTRUCTION** |  |  | 2019-01-24 | 2019-12-22 |  |  |  |  |  |  |  |  |  |  |  |
|  | 1.4.1 | **B07 - UNDER PLATFORM** |  |  | 2019-03-09 | 2019-09-26 |  |  |  |  |  |  |  |  |  |  |  |
|  | 6 | **SOUTH UNDER PLATFORM ZONE (8 TO 11)** |  |  | 2019-03-09 | 2019-08-27 |  |  |  |  |  |  |  |  |  |  |  |
| LOE-SUM3-010 |  | South . B07 - MEP Works; 1st & 2nd Fix | level of effort | 155.25d | 2019-03-09 | 2019-07-31 | RM02 | 122.5d | 0d | Saudi |  |  | MEP |  |  |  |  |
| LOE-SUM3-020 |  | South . B07 - MEP Works; Final Fix | level of effort | 147d | 2019-04-13 | 2019-08-27 | A9122 SS | 123.75d | 0d | Saudi |  |  | MEP |  |  |  |  |
|  | 2 | **B07 - UNDER PLATFORM ZONE 08** |  |  | 2019-04-22 | 2019-08-18 |  |  |  |  |  |  |  |  |  |  |  |
|  | 1.4.1.4.1.1.4.1.1 | **HVAC SYSTEM** |  |  | 2019-04-22 | 2019-06-20 |  |  |  |  |  |  |  |  |  |  |  |
|  | 1.4.1.4.1.1.4.1.1.1. | **1st Fix** |  |  | 2019-04-22 | 2019-05-08 |  |  |  |  |  |  |  |  |  |  |  |
| 1 |  | Hanger and support Installation - Duct |  | 6d | 2019-04-22 | 2019-04-27 | RM01, A2232 | 176.25d | 0d |  | Mechanical Crew [60 h] | 5.66 | MEP |  | 1546 | CON | 4 |
| 2 |  | Hanger and support Installation - CHW |  | 6d | 2019-04-22 | 2019-04-27 | 1 SS | 176.25d | 0d |  | Mechanical Crew [60 h] | 5.66 | MEP |  |  |  | 4 |
| 4 |  | Duct Installation |  | 12d | 2019-04-23 | 2019-05-05 | 1 SS+2d | 185.25d | 0d |  | HVAC [390 h]; Duct Installation [130 Sqmt] | 36.78 | MEP |  | 1549 | CON | 4 |
| 5 |  | Duct Insulation |  | 8d | 2019-04-27 | 2019-05-04 | 4 SS+3d | 209.25d | 33d |  | Duct Insulation [145 Sqmt]; HVAC [90 h] | 8.49 | MEP |  | 1552 | CON | 4 |
| 6 |  | Chilled Water Piping Installation |  | 12d | 2019-04-27 | 2019-05-08 | 2 | 176.25d | 0d |  | Mechanical Crew [120 h] | 11.32 | MEP |  |  |  | 4 |
|  | 1.4.1.4.1.1.4.1.1.-1 | **2nd Fix** |  |  | 2019-05-05 | 2019-05-27 |  |  |  |  |  |  |  |  |  |  |  |
| 07 |  | Installation of Duct Accessories (VD, FD, MSD etc....) |  | 12d | 2019-05-05 | 2019-05-15 | 4 | 196.25d | 20d |  | Mechanical Crew [120 h] | 11.32 | MEP |  |  |  | 4 |
| 10 |  | CRAC Units Installation |  | 15d | 2019-05-05 | 2019-05-19 | 4 | 185.25d | 9d |  | Mechanical Crew [150 h] | 14.15 | MEP |  |  |  | 4 |
| 12 |  | FCU Installation |  | 15d | 2019-05-05 | 2019-05-19 | 4 | 185.25d | 9d |  | Mechanical Crew [150 h] | 14.15 | MEP |  |  |  | 4 |
| 13 |  | VRF DX Units Installation |  | 12d | 2019-05-05 | 2019-05-15 | 4 | 188.25d | 12d |  | Mechanical Crew [120 h] | 11.32 | MEP |  |  |  | 4 |
| 14 |  | Installation of Attenuators |  | 10d | 2019-05-05 | 2019-05-14 | 4 | 190.25d | 14d |  | Mechanical Crew [100 h] | 9.43 | MEP |  |  |  | 4 |
| 15 |  | Installation of HVAC Fans |  | 10d | 2019-05-05 | 2019-05-14 | 4 | 190.25d | 14d |  | Mechanical Crew [100 h] | 9.43 | MEP |  |  |  | 4 |
| 17 |  | Pressurization Unit |  | 8d | 2019-05-05 | 2019-05-12 | 4 | 192.25d | 16d |  | Mechanical Crew [80 h] | 7.54 | MEP |  |  |  | 4 |
| 18 |  | Dosing pot |  | 5d | 2019-05-05 | 2019-05-09 | 4 | 195.25d | 19d |  | Mechanical Crew [50 h] | 4.71 | MEP |  |  |  | 4 |
| 19 |  | Air Handling Units Installation |  | 12d | 2019-05-05 | 2019-05-15 | 4 | 188.25d | 12d |  | Mechanical Crew [120 h] | 11.32 | MEP |  |  |  | 4 |
| 08 |  | Valves and Accessories |  | 10d | 2019-05-08 | 2019-05-18 | 6 | 176.25d | 0d |  | Mechanical Crew [100 h] | 9.43 | MEP |  |  |  | 4 |
| 16 |  | Air-Cooled Chillers |  | 15d | 2019-05-08 | 2019-05-22 | 6 | 181.25d | 5d |  | Mechanical Crew [150 h] | 14.15 | MEP |  |  |  | 4 |
| 20 |  | Chilled Water Pump Installation |  | 12d | 2019-05-08 | 2019-05-19 | 6 | 184.25d | 8d |  | Mechanical Crew [120 h] | 11.32 | MEP |  |  |  | 4 |
| 09 |  | Chilled Water Pipe Insulation and Cladding |  | 10d | 2019-05-18 | 2019-05-27 | 6, 08 | 176.25d | 0d |  | Mechanical Crew [100 h] | 9.43 | MEP |  |  |  | 4 |

| ID | WBS | Activity | Duration | Start | Finish | Predecessors | Total float | Free float | Resources | Cost | Discipline | AREA | MSP Activity ID | MEP-Phase |
| --- | --- | --- | --- | --- | --- | --- | --- | --- | --- | --- | --- | --- | --- | --- |
|  | 1.4.1.4.1.1.4.1.1.-2 | **HVAC_Final Fix** |  | 2019-05-27 | 2019-06-20 |  |  |  |  |  |  |  |  |  |
| 21 |  | Equuipment Connection | 8d | 2019-05-27 | 2019-06-03 | 20, 19, 16, 15, 14, 10, 12, 13, 18, 17, 09 | 176.25d | 0d | Mechanical Crew [80 h] | 7.54 | MEP | 4 |  |  |
| 22 |  | Air Outlets (Grills, Diffusers, Registers etc...) | 15d | 2019-06-03 | 2019-06-20 | 07, 4, 5, 21, LOE-SUM3-020 FF | 176.25d | 0d | Mechanical Crew [150 h] | 14.15 | MEP | 4 |  |  |
|  | 1.4.1.4.1.1.4.1.2 | **PLUMBING SYSTEM** |  | 2019-04-22 | 2019-06-02 |  |  |  |  |  |  |  |  |  |
|  | 1.4.1.4.1.1.4.1.2.1. | **1st Fix** |  | 2019-04-22 | 2019-05-15 |  |  |  |  |  |  |  |  |  |
| 23 |  | Hanger and support Installation | 10d | 2019-04-22 | 2019-04-30 | RM01 | 167.25d | 0d | Plumbing Crew [100 h] | 9.43 | MEP | 4 | 1566 | CON |
| 24 |  | Drainage and Vent Pipe & Fittings | 20d | 2019-04-27 | 2019-05-14 | 23 SS+5d | 215.25d | 1d | Plumbing Crew [200 h] | 18.86 | MEP | 4 | 1573 | CON |
| 25 |  | Domestic Water Pipe & Fittings | 20d | 2019-04-27 | 2019-05-15 | 23 SS+6d | 167.25d | 0d | Plumbing Crew [200 h] | 18.86 | MEP | 4 | 1570 | CON |
|  | 1.4.1.4.1.1.4.1.2.-1 | **2nd Fix** |  | 2019-05-15 | 2019-05-30 |  |  |  |  |  |  |  |  |  |
| 26 |  | Domestic Water Valves | 12d | 2019-05-15 | 2019-05-27 | 25 | 167.25d | 0d | Plumbing Crew [120 h] | 11.32 | MEP | 4 | 1571 | CON |
| 27 |  | Sewege Pumps Installation | 5d | 2019-05-15 | 2019-05-20 | 24, 25 | 214.25d | 0d | Plumbing Crew [50 h] | 4.71 | MEP | 4 |  |  |
| 28 |  | Leak Test | 4d | 2019-05-27 | 2019-05-30 | 26 | 175.25d | 0d | Plumbing Crew [40 h] | 3.77 | MEP | 4 | 1572 | CON |
|  | 1.4.1.4.1.1.4.1.2.-2 | **PLM_Final Fix** |  | 2019-05-30 | 2019-06-02 |  |  |  |  |  |  |  |  |  |
| 29 |  | Floor Drain | 2d | 2019-05-30 | 2019-06-02 | 31 SS | 206.25d | 0d | Plumbing Crew [20 h] | 1.89 | MEP | 4 |  |  |
| 30 |  | Eye Wash | 2d | 2019-05-30 | 2019-06-02 | 32 SS | 206.25d | 10d | Plumbing Crew [20 h] | 1.89 | MEP | 4 |  |  |
| 31 |  | Water Heaters | 2d | 2019-05-30 | 2019-06-02 | 28, 24, 25 | 206.25d | 0d | Plumbing Crew [20 h] | 1.89 | MEP | 4 |  |  |
| 32 |  | Wash Basin / Water Closet | 2d | 2019-05-30 | 2019-06-02 | 29 SS | 206.25d | 0d | Plumbing Crew [20 h] | 1.89 | MEP | 4 |  |  |
|  | 1.4.1.4.1.1.4.1.3 | **ELECTRICAL / CONTROLS** |  | 2019-04-22 | 2019-08-18 |  |  |  |  |  |  |  |  |  |
|  | 1.4.1.4.1.1.4.1.3.1. | **1st Fix** |  | 2019-04-22 | 2019-05-18 |  |  |  |  |  |  |  |  |  |
| 33 |  | Installation of Conduits and Boxes | 12d | 2019-04-22 | 2019-05-02 | RM01, LOE-SUM3-010 FF | 117.25d | 0d | Electrical Crew [120 h] | 11.32 | MEP | 4 | 1592 | CON |
| 34 |  | Installation of Cable Tray, Ladder and Trunk | 20d | 2019-04-29 | 2019-05-18 | 33 SS+8d | 178.25d | 0d | Electrical Crew [200 h] | 18.86 | MEP | 4 | 1593 | CON |
|  | 1.4.1.4.1.1.4.1.3.-1 | **2nd Fix** |  | 2019-05-02 | 2019-07-31 |  |  |  |  |  |  |  |  |  |
| 35 |  | Grounding and Bonding Installation | 20d | 2019-05-02 | 2019-05-21 | 33 | 117.25d | 0d | Electrical Crew [200 h] | 18.86 | MEP | 4 | 1596 | CON |
| 45 |  | Installation of Bus Duct System | 20d | 2019-05-18 | 2019-06-09 | 34 | 178.25d | 56d | Electrical Crew [200 h] | 18.86 | MEP | 4 |  |  |
| 36 |  | Wire Pulling | 20d | 2019-05-21 | 2019-06-12 | 35 | 117.25d | 0d | Electrical Crew [200 h] | 18.86 | MEP | 4 |  |  |
| 37 |  | Power Cable Laying | 25d | 2019-06-12 | 2019-07-06 | 36, 35 | 117.25d | 0d | Electrical Crew [250 h] | 23.58 | MEP | 4 | 1600 | CON |
| 38 |  | Continuity Test - Power Cables | 4d | 2019-07-06 | 2019-07-09 | 37 | 145.25d | 23d | Electrical Crew [40 h] | 3.77 | MEP | 4 | 1601 | CON |
| 39 |  | Installation of Disconnect Switch | 8d | 2019-07-06 | 2019-07-13 | 37, 36 | 141.25d | 19d | Electrical Crew [80 h] | 7.54 | MEP | 4 |  |  |
| 40 |  | Installation of Switch Boards (MDB, EMDB) | 15d | 2019-07-06 | 2019-07-20 | 37, 36 | 117.25d | 0d | Electrical Crew [150 h] | 14.15 | MEP | 4 |  |  |
| 41 |  | Installation of Panel Boards | 15d | 2019-07-06 | 2019-07-20 | 37, 36 | 117.25d | 0d | Electrical Crew [150 h] | 14.15 | MEP | 4 |  |  |
| 42 |  | Installation of MCC | 15d | 2019-07-06 | 2019-07-20 | 37, 36 | 117.25d | 0d | Electrical Crew [150 h] | 14.15 | MEP | 4 |  |  |
| 44 |  | Installation of Central Battery Equipment | 6d | 2019-07-06 | 2019-07-11 | 37, 36 | 143.25d | 21d | Electrical Crew [60 h] | 5.66 | MEP | 4 |  |  |
| 46 |  | Installation of Lighting Control System | 12d | 2019-07-06 | 2019-07-17 | 37, 36 | 120.25d | 3d | Electrical Crew [120 h] | 11.32 | MEP | 4 |  |  |
| 43 |  | Installation of Wiring Devices and Outlets | 12d | 2019-07-20 | 2019-07-31 | 36, 42, 41, 40, 46 | 117.25d | 0d | Electrical Crew [120 h] | 11.32 | MEP | 4 |  |  |

| ID | WBS | Activity | Duration | Start | Finish | Predecessors | Total float | Free float | Resources | Cost | Discipline | AREA | MSP Activity ID | MEP-Phase |
| --- | --- | --- | --- | --- | --- | --- | --- | --- | --- | --- | --- | --- | --- | --- |
|  | 1.4.1.4.1.1.4.1.3.-2 | **Elec._Final Fix** |  | 2019-07-20 | 2019-08-18 |  |  |  |  |  |  |  |  |  |
| 49 |  | Panel Board Termination | 8d | 2019-07-20 | 2019-07-27 | 40, 41, 42 | 132.25d | 10d | Electrical Crew [80 h] | 7.54 | MEP | 4 |  |  |
| 48 |  | Wiring devices Termination | 6d | 2019-07-31 | 2019-08-05 | 44, 39, 45, 46, 43, 38 | 122.25d | 0d | Electrical Crew [60 h] | 5.66 | MEP | 4 | 1617 | CON |
| 47 |  | Lighting Fixtures Installation and Termination | 10d | 2019-08-06 | 2019-08-18 | 37, 36, 49, 48 | 122.25d | 0d | Electrical Crew [100 h] | 9.43 | MEP | 4 | 1616 | CON |
|  | 1.4.1.4.1.1.4.1.4 | **FIRE FIGHTING SYSTEM** |  | 2019-04-22 | 2019-07-27 |  |  |  |  |  |  |  |  |  |
|  | 1.4.1.4.1.1.4.1.4.1. | **1st Fix** |  | 2019-04-22 | 2019-06-02 |  |  |  |  |  |  |  |  |  |
| 50 |  | Fire Fighting Hangers & Supports | 15d | 2019-04-22 | 2019-05-05 | RM01 | 146.25d | 0d | Fire Fighting Crew [150 h] | 14.15 | MEP | 4 | 1622 | CON |
| 51 |  | Pipe Installation | 30d | 2019-05-06 | 2019-06-02 | 50 | 146.25d | 0d | FIRE FIGHTING [180 h]; FF pipe [107 Limt] | 16.97 | MEP | 4 | 1625 | CON |
|  | 1.4.1.4.1.1.4.1.4.-1 | **2nd Fix** |  | 2019-06-03 | 2019-07-03 |  |  |  |  |  |  |  |  |  |
| 52 |  | Valve and Accessories Installation | 20d | 2019-06-03 | 2019-06-24 | 51, 50 | 146.25d | 0d | Fire Fighting Crew [200 h] | 18.86 | MEP | 4 | 1627 | CON |
| 53 |  | Leak Test | 10d | 2019-06-25 | 2019-07-03 | 52 | 146.25d | 0d | Fire Fighting Crew [100 h] | 9.43 | MEP | 4 | 1631 | CON |
|  | 1.4.1.4.1.1.4.1.4.-2 | **FF_Final Fix** |  | 2019-07-04 | 2019-07-27 |  |  |  |  |  |  |  |  |  |
| 54 |  | Installation of Sprinklers | 15d | 2019-07-04 | 2019-07-17 | 51, 52, 53 | 162.25d | 0d | Fire Fighting Crew [150 h] | 14.15 | MEP | 4 | 1633 | CON |
| 55 |  | Installation of Fire hose Cabinet | 5d | 2019-07-18 | 2019-07-22 | 51, 54 | 212.25d | 0d | Fire Fighting Crew [50 h] | 4.71 | MEP | 4 |  |  |
| 56 |  | Instalaltion of Fire Extinguisher | 10d | 2019-07-18 | 2019-07-27 | 51, 54, 55 FF | 207.25d | 0d | Fire Fighting Crew [100 h] | 9.43 | MEP | 4 |  | CON |
|  | 1 | **B07 - UNDER PLATFORM ZONE 09** |  | 2019-04-22 | 2019-08-27 |  |  |  |  |  |  |  |  |  |
|  | 1.4.1.4.1.1.4.1.1 | **HVAC SYSTEM** |  | 2019-04-22 | 2019-07-04 |  |  |  |  |  |  |  |  |  |
|  | 1.4.1.4.1.1.4.1.1.1. | **1st Fix** |  | 2019-04-22 | 2019-05-08 |  |  |  |  |  |  |  |  |  |
| A4542 |  | Hanger and support Installation - Duct | 6d | 2019-04-22 | 2019-04-27 | RM01 | 183.25d | 0d | Mechanical Crew [60 h] | 5.66 | MEP | 4 | 1546 | CON |
| A4612 |  | Hanger and support Installation - CHW | 6d | 2019-04-22 | 2019-04-27 | A4542 SS | 183.25d | 0d | Mechanical Crew [60 h] | 5.66 | MEP | 4 |  |  |
| A4522 |  | Duct Installation | 12d | 2019-04-23 | 2019-05-05 | A4542 SS+2d | 200.25d | 0d | HVAC [390 h]; Duct Installation [130 Sqmt] | 36.78 | MEP | 4 | 1549 | CON |
| A4532 |  | Duct Insulation | 8d | 2019-04-27 | 2019-05-04 | A4522 SS+3d | 224.25d | 48d | Duct Insulation [145 Sqmt]; HVAC [90 h] | 8.49 | MEP | 4 | 1552 | CON |
| A4632 |  | Chilled Water Piping Installation | 12d | 2019-04-27 | 2019-05-08 | A4612 | 183.25d | 0d | Mechanical Crew [120 h] | 11.32 | MEP | 4 |  |  |
|  | 1.4.1.4.1.1.4.1.1.-1 | **2nd Fix** |  | 2019-05-05 | 2019-05-27 |  |  |  |  |  |  |  |  |  |
| A4622 |  | Installation of Duct Accessories (VD, FD, MSD etc....) | 12d | 2019-05-05 | 2019-05-15 | A4522 | 211.25d | 35d | Mechanical Crew [120 h] | 11.32 | MEP | 4 |  |  |
| A4722 |  | CRAC Units Installation | 15d | 2019-05-05 | 2019-05-19 | A4522 | 200.25d | 17d | Mechanical Crew [150 h] | 14.15 | MEP | 4 |  |  |
| A4732 |  | FCU Installation | 15d | 2019-05-05 | 2019-05-19 | A4522 | 200.25d | 17d | Mechanical Crew [150 h] | 14.15 | MEP | 4 |  |  |
| A4742 |  | VRF DX Units Installation | 12d | 2019-05-05 | 2019-05-15 | A4522 | 203.25d | 20d | Mechanical Crew [120 h] | 11.32 | MEP | 4 |  |  |
| A4752 |  | Installation of Attenuators | 10d | 2019-05-05 | 2019-05-14 | A4522 | 205.25d | 22d | Mechanical Crew [100 h] | 9.43 | MEP | 4 |  |  |
| A4762 |  | Installation of HVAC Fans | 10d | 2019-05-05 | 2019-05-14 | A4522 | 205.25d | 22d | Mechanical Crew [100 h] | 9.43 | MEP | 4 |  |  |
| A4782 |  | Pressurization Unit | 8d | 2019-05-05 | 2019-05-12 | A4522 | 207.25d | 24d | Mechanical Crew [80 h] | 7.54 | MEP | 4 |  |  |
| A4792 |  | Dosing pot | 5d | 2019-05-05 | 2019-05-09 | A4522 | 210.25d | 27d | Mechanical Crew [50 h] | 4.71 | MEP | 4 |  |  |
| A4812 |  | Air Handling Units Installation | 12d | 2019-05-05 | 2019-05-15 | A4522 | 203.25d | 20d | Mechanical Crew [120 h] | 11.32 | MEP | 4 |  |  |
| A4652 |  | Valves and Accessories | 10d | 2019-05-08 | 2019-05-18 | A4632 | 183.25d | 0d | Mechanical Crew [100 h] | 9.43 | MEP | 4 |  |  |
| A4772 |  | Air-Cooled Chillers | 15d | 2019-05-08 | 2019-05-22 | A4632 | 196.25d | 13d | Mechanical Crew [150 h] | 14.15 | MEP | 4 |  |  |
| A4822 |  | Chilled Water Pump Installation | 12d | 2019-05-08 | 2019-05-19 | A4632 | 199.25d | 16d | Mechanical Crew [120 h] | 11.32 | MEP | 4 |  |  |
| A4662 |  | Chilled Water Pipe Insulation and Cladding | 10d | 2019-05-18 | 2019-05-27 | A4632, A4652 | 183.25d | 8d | Mechanical Crew [100 h] | 9.43 | MEP | 4 |  |  |

| ID | WBS | Activity | Duration | Start | Finish | Predecessors | Total float | Free float | Resources | Cost | Discipline | AREA | MSP Activity ID | MEP-Phase |
| --- | --- | --- | --- | --- | --- | --- | --- | --- | --- | --- | --- | --- | --- | --- |
|  | 1.4.1.4.1.1.4.1.1.-2 | **HVAC_Final Fix** |  | 2019-06-03 | 2019-07-04 |  |  |  |  |  |  |  |  |  |
| A4802 |  | Equuipment Connection | 8d | 2019-06-03 | 2019-06-15 | A4822, A4812, A4772, A4762, A4752, A4722, A4732, A4742, A4792, A4782, A4662, 21 | 183.25d | 7d | Mechanical Crew [80 h] | 7.54 | MEP | 4 |  |  |
| A4642 |  | Air Outlets (Grills, Diffusers, Registers etc...) | 15d | 2019-06-20 | 2019-07-04 | A4622, A4522, A4532, 22, A4802 | 176.25d | 166.75d | Mechanical Crew [150 h] | 14.15 | MEP | 4 |  |  |
|  | 1.4.1.4.1.1.4.1.2 | **PLUMBING SYSTEM** |  | 2019-04-22 | 2019-06-16 |  |  |  |  |  |  |  |  |  |
|  | 1.4.1.4.1.1.4.1.2.1. | **1st Fix** |  | 2019-04-22 | 2019-05-15 |  |  |  |  |  |  |  |  |  |
| A4402 |  | Hanger and support Installation | 10d | 2019-04-22 | 2019-04-30 | RM01 | 179.25d | 0d | Plumbing Crew [100 h] | 9.43 | MEP | 4 | 1566 | CON |
| A4442 |  | Drainage and Vent Pipe & Fittings | 20d | 2019-04-27 | 2019-05-14 | A4402 SS+5d | 220.25d | 6d | Plumbing Crew [200 h] | 18.86 | MEP | 4 | 1573 | CON |
| A4412 |  | Domestic Water Pipe & Fittings | 20d | 2019-04-27 | 2019-05-15 | A4402 SS+6d | 179.25d | 5d | Plumbing Crew [200 h] | 18.86 | MEP | 4 | 1570 | CON |
|  | 1.4.1.4.1.1.4.1.2.-1 | **2nd Fix** |  | 2019-05-20 | 2019-06-15 |  |  |  |  |  |  |  |  |  |
| A4682 |  | Sewege Pumps Installation | 5d | 2019-05-20 | 2019-05-25 | A4442, A4412, 27 | 214.25d | 18d | Plumbing Crew [50 h] | 4.71 | MEP | 4 |  |  |
| A4422 |  | Domestic Water Valves | 12d | 2019-05-27 | 2019-06-10 | A4412, 26 | 167.25d | 0d | Plumbing Crew [120 h] | 11.32 | MEP | 4 | 1571 | CON |
| A4432 |  | Leak Test | 4d | 2019-06-11 | 2019-06-15 | A4422, 28 | 167.25d | 0d | Plumbing Crew [40 h] | 3.77 | MEP | 4 | 1572 | CON |
|  | 1.4.1.4.1.1.4.1.2.-2 | **PLM_Final Fix** |  | 2019-06-15 | 2019-06-16 |  |  |  |  |  |  |  |  |  |
| A4672 |  | Water Heaters | 2d | 2019-06-15 | 2019-06-16 | A4432, A4442, A4412 | 196.25d | 0d | Plumbing Crew [20 h] | 1.89 | MEP | 4 |  |  |
| A4692 |  | Floor Drain | 2d | 2019-06-15 | 2019-06-16 | A4672 SS | 196.25d | 0d | Plumbing Crew [20 h] | 1.89 | MEP | 4 |  |  |
| A4702 |  | Wash Basin / Water Closet | 2d | 2019-06-15 | 2019-06-16 | A4692 SS | 196.25d | 0d | Plumbing Crew [20 h] | 1.89 | MEP | 4 |  |  |
| A4712 |  | Eye Wash | 2d | 2019-06-15 | 2019-06-16 | A4702 SS, 30, A4682 | 196.25d | 173.75d | Plumbing Crew [20 h] | 1.89 | MEP | 4 |  |  |
|  | 1.4.1.4.1.1.4.1.3 | **ELECTRICAL / CONTROLS** |  | 2019-04-22 | 2019-08-27 |  |  |  |  |  |  |  |  |  |
|  | 1.4.1.4.1.1.4.1.3.1. | **1st Fix** |  | 2019-04-22 | 2019-05-18 |  |  |  |  |  |  |  |  |  |
| A4502 |  | Installation of Conduits and Boxes | 12d | 2019-04-22 | 2019-05-02 | RM01 | 117.25d | 0d | Electrical Crew [120 h] | 11.32 | MEP | 4 | 1592 | CON |
| A4512 |  | Installation of Cable Tray, Ladder and Trunk | 20d | 2019-04-29 | 2019-05-18 | A4502 SS+8d | 188.25d | 0d | Electrical Crew [200 h] | 18.86 | MEP | 4 | 1593 | CON |
|  | 1.4.1.4.1.1.4.1.3.-1 | **2nd Fix** |  | 2019-05-02 | 2019-07-31 |  |  |  |  |  |  |  |  |  |
| A4472 |  | Grounding and Bonding Installation | 20d | 2019-05-02 | 2019-05-21 | A4502 | 117.25d | 0d | Electrical Crew [200 h] | 18.86 | MEP | 4 | 1596 | CON |
| A4892 |  | Installation of Bus Duct System | 20d | 2019-05-18 | 2019-06-09 | A4512 | 188.25d | 56d | Electrical Crew [200 h] | 18.86 | MEP | 4 |  |  |
| A4832 |  | Wire Pulling | 20d | 2019-05-21 | 2019-06-12 | A4472 | 117.25d | 0d | Electrical Crew [200 h] | 18.86 | MEP | 4 |  |  |
| A4452 |  | Power Cable Laying | 25d | 2019-06-12 | 2019-07-06 | A4832, A4472 | 117.25d | 0d | Electrical Crew [250 h] | 23.58 | MEP | 4 | 1600 | CON |
| A4462 |  | Continuity Test - Power Cables | 4d | 2019-07-06 | 2019-07-09 | A4452 | 155.25d | 23d | Electrical Crew [40 h] | 3.77 | MEP | 4 | 1601 | CON |
| A4842 |  | Installation of Central Battery Equipment | 6d | 2019-07-06 | 2019-07-11 | A4452, A4832 | 153.25d | 21d | Electrical Crew [60 h] | 5.66 | MEP | 4 |  |  |
| A4852 |  | Installation of Disconnect Switch | 8d | 2019-07-06 | 2019-07-13 | A4452, A4832 | 151.25d | 19d | Electrical Crew [80 h] | 7.54 | MEP | 4 |  |  |
| A4872 |  | Installation of Switch Boards (MDB, EMDB) | 15d | 2019-07-06 | 2019-07-20 | A4452, A4832 | 117.25d | 0d | Electrical Crew [150 h] | 14.15 | MEP | 4 |  |  |
| A4882 |  | Installation of Panel Boards | 15d | 2019-07-06 | 2019-07-20 | A4452, A4832 | 117.25d | 0d | Electrical Crew [150 h] | 14.15 | MEP | 4 |  |  |
| A4902 |  | Installation of MCC | 15d | 2019-07-06 | 2019-07-20 | A4452, A4832 | 117.25d | 0d | Electrical Crew [150 h] | 14.15 | MEP | 4 |  |  |
| A4912 |  | Installation of Lighting Control System | 12d | 2019-07-06 | 2019-07-17 | A4452, A4832 | 120.25d | 3d | Electrical Crew [120 h] | 11.32 | MEP | 4 |  |  |
| A4862 |  | Installation of Wiring Devices and Outlets | 12d | 2019-07-20 | 2019-07-31 | A4832, A4902, A4882, A4872, A4912 | 117.25d | 0d | Electrical Crew [120 h] | 11.32 | MEP | 4 |  |  |

| ID | WBS | Activity | Duration | Start | Finish | Predecessors | Total float | Free float | Resources | Cost | Discipline | AREA | MSP Activity ID | MEP-Phase |
| --- | --- | --- | --- | --- | --- | --- | --- | --- | --- | --- | --- | --- | --- | --- |
|  | 1.4.1.4.1.1.4.1.3.-2 | **Elec._Final Fix** |  | 2019-07-20 | 2019-08-27 |  |  |  |  |  |  |  |  |  |
| A4922 |  | Panel Board Termination | 8d | 2019-07-20 | 2019-07-27 | A4872, A4882, A4902 | 142.25d | 20d | Electrical Crew [80 h] | 7.54 | MEP | 4 |  |  |
| A4492 |  | Wiring devices Termination | 6d | 2019-07-31 | 2019-08-05 | A4842, A4852, A4892, A4912, A4862, A4462 | 132.25d | 10d | Electrical Crew [60 h] | 5.66 | MEP | 4 | 1617 | CON |
| A4482 |  | Lighting Fixtures Installation and Termination | 10d | 2019-08-19 | 2019-08-27 | A4452, A4832, 47, A4922, A4492, LOE-SUM3-020 FF | 122.25d | 107.75d | Electrical Crew [100 h] | 9.43 | MEP | 4 | 1616 | CON |
|  | 1.4.1.4.1.1.4.1.4 | **FIRE FIGHTING SYSTEM** |  | 2019-04-22 | 2019-08-05 |  |  |  |  |  |  |  |  |  |
|  | 1.4.1.4.1.1.4.1.4.1. | **1st Fix** |  | 2019-04-22 | 2019-06-02 |  |  |  |  |  |  |  |  |  |
| A4582 |  | Fire Fighting Hangers & Supports | 15d | 2019-04-22 | 2019-05-05 | RM01 | 146.25d | 0d | Fire Fighting Crew [150 h] | 14.15 | MEP | 4 | 1622 | CON |
| A4552 |  | Pipe Installation | 30d | 2019-05-06 | 2019-06-02 | A4582 | 146.25d | 0d | FF pipe [103 Limt]; FIRE FIGHTING [180 h] | 16.97 | MEP | 4 | 1625 | CON |
|  | 1.4.1.4.1.1.4.1.4.-1 | **2nd Fix** |  | 2019-06-03 | 2019-07-03 |  |  |  |  |  |  |  |  |  |
| A4562 |  | Valve and Accessories Installation | 20d | 2019-06-03 | 2019-06-24 | A4552, A4582 | 146.25d | 0d | Fire Fighting Crew [200 h] | 18.86 | MEP | 4 | 1627 | CON |
| A4572 |  | Leak Test | 10d | 2019-06-25 | 2019-07-03 | A4562 | 146.25d | 0d | Fire Fighting Crew [100 h] | 9.43 | MEP | 4 | 1631 | CON |
|  | 1.4.1.4.1.1.4.1.4.-2 | **FF_Final Fix** |  | 2019-07-04 | 2019-08-05 |  |  |  |  |  |  |  |  |  |
| A4592 |  | Installation of Sprinklers | 15d | 2019-07-04 | 2019-07-17 | A4552, A4562, A4572 | 162.25d | 5d | Fire Fighting Crew [150 h] | 14.15 | MEP | 4 | 1633 | CON |
| A4932 |  | Installation of Fire hose Cabinet | 5d | 2019-07-23 | 2019-07-27 | A4552, A4592, 55 | 217.25d | 10d | Fire Fighting Crew [50 h] | 4.71 | MEP | 4 |  |  |
| A4602 |  | Instalaltion of Fire Extinguisher | 10d | 2019-07-28 | 2019-08-05 | A4552, A4592, 56, A4932 FF | 207.25d | 207.75d | Fire Fighting Crew [100 h] | 9.43 | MEP | 4 |  | CON |
|  | 3 | **B07 - UNDER PLATFORM ZONE 10** |  | 2019-03-09 | 2019-07-01 |  |  |  |  |  |  |  |  |  |
|  | 1.4.1.4.1.1.4.1.1 | **HVAC SYSTEM** |  | 2019-03-09 | 2019-05-04 |  |  |  |  |  |  |  |  |  |
|  | 1.4.1.4.1.1.4.1.1.1. | **1st Fix** |  | 2019-03-09 | 2019-03-25 |  |  |  |  |  |  |  |  |  |
| A6702 |  | Hanger and support Installation - Duct | 6d | 2019-03-09 | 2019-03-13 | RM02 | 238.25d | 0d | Mechanical Crew [60 h] | 5.66 | MEP | 5 | 1546 | CON |
| A6772 |  | Hanger and support Installation - CHW | 6d | 2019-03-09 | 2019-03-13 | A6702 SS | 238.25d | 0d | Mechanical Crew [60 h] | 5.66 | MEP | 5 |  |  |
| A6682 |  | Duct Installation | 12d | 2019-03-10 | 2019-03-21 | A6702 SS+2d | 247.75d | 0d | HVAC [390 h]; Duct Installation [130 Sqmt] | 36.78 | MEP | 5 | 1549 | CON |
| A6692 |  | Duct Insulation | 8d | 2019-03-13 | 2019-03-20 | A6682 SS+3d | 271.75d | 33d | Duct Insulation [145 Sqmt]; HVAC [128 h] | 12.07 | MEP | 5 | 1552 | CON |
| A6792 |  | Chilled Water Piping Installation | 12d | 2019-03-13 | 2019-03-25 | A6772 | 238.25d | 0d | Mechanical Crew [120 h] | 11.32 | MEP | 5 |  |  |
|  | 1.4.1.4.1.1.4.1.1.-1 | **2nd Fix** |  | 2019-03-21 | 2019-04-13 |  |  |  |  |  |  |  |  |  |
| A6782 |  | Installation of Duct Accessories (VD, FD, MSD etc....) | 12d | 2019-03-21 | 2019-04-01 | A6682 | 258.75d | 20d | Mechanical Crew [120 h] | 11.32 | MEP | 5 |  |  |
| A6882 |  | CRAC Units Installation | 15d | 2019-03-21 | 2019-04-04 | A6682 | 247.75d | 9d | Mechanical Crew [150 h] | 14.15 | MEP | 5 |  |  |
| A6892 |  | FCU Installation | 15d | 2019-03-21 | 2019-04-04 | A6682 | 247.75d | 9d | Mechanical Crew [150 h] | 14.15 | MEP | 5 |  |  |
| A6902 |  | VRF DX Units Installation | 12d | 2019-03-21 | 2019-04-01 | A6682 | 250.75d | 12d | Mechanical Crew [120 h] | 11.32 | MEP | 5 |  |  |
| A6912 |  | Installation of Attenuators | 10d | 2019-03-21 | 2019-03-31 | A6682 | 252.75d | 14d | Mechanical Crew [100 h] | 9.43 | MEP | 5 |  |  |
| A6922 |  | Installation of HVAC Fans | 10d | 2019-03-21 | 2019-03-31 | A6682 | 252.75d | 14d | Mechanical Crew [100 h] | 9.43 | MEP | 5 |  |  |
| A6942 |  | Pressurization Unit | 8d | 2019-03-21 | 2019-03-28 | A6682 | 254.75d | 16d | Mechanical Crew [80 h] | 7.54 | MEP | 5 |  |  |
| A6952 |  | Dosing pot | 5d | 2019-03-21 | 2019-03-26 | A6682 | 257.75d | 19d | Mechanical Crew [50 h] | 4.71 | MEP | 5 |  |  |
| A6972 |  | Air Handling Units Installation | 12d | 2019-03-21 | 2019-04-01 | A6682 | 250.75d | 12d | Mechanical Crew [120 h] | 11.32 | MEP | 5 |  |  |
| A6812 |  | Valves and Accessories | 10d | 2019-03-25 | 2019-04-03 | A6792 | 238.25d | 0d | Mechanical Crew [100 h] | 9.43 | MEP | 5 |  |  |
| A6932 |  | Air-Cooled Chillers | 15d | 2019-03-25 | 2019-04-08 | A6792 | 243.75d | 5d | Mechanical Crew [150 h] | 14.15 | MEP | 5 |  |  |
| A6982 |  | Chilled Water Pump Installation | 12d | 2019-03-25 | 2019-04-04 | A6792 | 246.75d | 8d | Mechanical Crew [120 h] | 11.32 | MEP | 5 |  |  |
| A6822 |  | Chilled Water Pipe Insulation and Cladding | 10d | 2019-04-03 | 2019-04-13 | A6792, A6812 | 238.25d | 0d | Mechanical Crew [100 h] | 9.43 | MEP | 5 |  |  |

| ID | WBS | Activity | Duration | Start | Finish | Predecessors | Total float | Free float | Resources | Cost | Discipline | AREA | MSP Activity ID | MEP-Phase |
| --- | --- | --- | --- | --- | --- | --- | --- | --- | --- | --- | --- | --- | --- | --- |
|  | 1.4.1.4.1.1.4.1.1.-2 | **HVAC_Final Fix** |  | 2019-04-13 | 2019-05-04 |  |  |  |  |  |  |  |  |  |
| A6962 |  | Equuipment Connection | 8d | 2019-04-13 | 2019-04-20 | A6982, A6972, A6932, A6922, A6912, A6882, A6892, A6902, A6952, A6942, A6822 | 238.75d | 0d | Mechanical Crew [80 h] | 7.54 | MEP | 5 |  |  |
| A6802 |  | Air Outlets (Grills, Diffusers, Registers etc...) | 15d | 2019-04-20 | 2019-05-04 | A6782, A6682, A6692, A6962 | 238.75d | 229.25d | Mechanical Crew [150 h] | 14.15 | MEP | 5 |  |  |
|  | 1.4.1.4.1.1.4.1.2 | **PLUMBING SYSTEM** |  | 2019-03-09 | 2019-04-18 |  |  |  |  |  |  |  |  |  |
|  | 1.4.1.4.1.1.4.1.2.1. | **1st Fix** |  | 2019-03-09 | 2019-04-01 |  |  |  |  |  |  |  |  |  |
| A6562 |  | Hanger and support Installation | 10d | 2019-03-09 | 2019-03-17 | RM02 | 234.25d | 0d | Plumbing Crew [100 h] | 9.43 | MEP | 5 | 1566 | CON |
| A6602 |  | Drainage and Vent Pipe & Fittings | 20d | 2019-03-13 | 2019-03-31 | A6562 SS+5d | 267.75d | 1d | Plumbing Crew [200 h] | 18.86 | MEP | 5 | 1573 | CON |
| A6572 |  | Domestic Water Pipe & Fittings | 20d | 2019-03-13 | 2019-04-01 | A6562 SS+6d | 234.25d | 0d | Plumbing Crew [200 h] | 18.86 | MEP | 5 | 1570 | CON |
|  | 1.4.1.4.1.1.4.1.2.-1 | **2nd Fix** |  | 2019-04-01 | 2019-04-16 |  |  |  |  |  |  |  |  |  |
| A6582 |  | Domestic Water Valves | 12d | 2019-04-01 | 2019-04-13 | A6572 | 234.25d | 0d | Plumbing Crew [120 h] | 11.32 | MEP | 5 | 1571 | CON |
| A6842 |  | Sewege Pumps Installation | 5d | 2019-04-01 | 2019-04-06 | A6602, A6572 | 266.75d | 11d | Plumbing Crew [50 h] | 4.71 | MEP | 5 |  |  |
| A6592 |  | Leak Test | 4d | 2019-04-13 | 2019-04-16 | A6582 | 234.25d | 0d | Plumbing Crew [40 h] | 3.77 | MEP | 5 | 1572 | CON |
|  | 1.4.1.4.1.1.4.1.2.-2 | **PLM_Final Fix** |  | 2019-04-16 | 2019-04-18 |  |  |  |  |  |  |  |  |  |
| A6832 |  | Water Heaters | 2d | 2019-04-16 | 2019-04-18 | A6592, A6602, A6572 | 255.75d | 0d | Plumbing Crew [20 h] | 1.89 | MEP | 5 |  |  |
| A6852 |  | Floor Drain | 2d | 2019-04-16 | 2019-04-18 | A6832 SS | 255.75d | 0d | Plumbing Crew [20 h] | 1.89 | MEP | 5 |  |  |
| A6862 |  | Wash Basin / Water Closet | 2d | 2019-04-16 | 2019-04-18 | A6852 SS | 255.75d | 0d | Plumbing Crew [20 h] | 1.89 | MEP | 5 |  |  |
| A6872 |  | Eye Wash | 2d | 2019-04-16 | 2019-04-18 | A6862 SS, A6842 | 255.75d | 233.25d | Plumbing Crew [20 h] | 1.89 | MEP | 5 |  |  |
|  | 1.4.1.4.1.1.4.1.3 | **ELECTRICAL / CONTROLS** |  | 2019-03-09 | 2019-07-01 |  |  |  |  |  |  |  |  |  |
|  | 1.4.1.4.1.1.4.1.3.1. | **1st Fix** |  | 2019-03-09 | 2019-04-03 |  |  |  |  |  |  |  |  |  |
| A6662 |  | Installation of Conduits and Boxes | 12d | 2019-03-09 | 2019-03-19 | RM02 | 172.25d | 0d | Electrical Crew [120 h] | 11.32 | MEP | 5 | 1592 | CON |
| A6672 |  | Installation of Cable Tray, Ladder and Trunk | 20d | 2019-03-16 | 2019-04-03 | A6662 SS+8d | 235.75d | 0d | Electrical Crew [200 h] | 18.86 | MEP | 5 | 1593 | CON |
|  | 1.4.1.4.1.1.4.1.3.-1 | **2nd Fix** |  | 2019-03-19 | 2019-06-17 |  |  |  |  |  |  |  |  |  |
| A6632 |  | Grounding and Bonding Installation | 20d | 2019-03-19 | 2019-04-07 | A6662 | 172.25d | 0d | Electrical Crew [200 h] | 18.86 | MEP | 5 | 1596 | CON |
| A7052 |  | Installation of Bus Duct System | 20d | 2019-04-03 | 2019-04-22 | A6672 | 235.75d | 56d | Electrical Crew [200 h] | 18.86 | MEP | 5 |  |  |
| A6992 |  | Wire Pulling | 20d | 2019-04-07 | 2019-04-25 | A6632 | 172.25d | 0d | Electrical Crew [200 h] | 18.86 | MEP | 5 |  |  |
| A6612 |  | Power Cable Laying | 25d | 2019-04-25 | 2019-05-19 | A6992, A6632 | 172.25d | 0d | Electrical Crew [250 h] | 23.58 | MEP | 5 | 1600 | CON |
| A6622 |  | Continuity Test - Power Cables | 4d | 2019-05-19 | 2019-05-22 | A6612 | 202.75d | 23d | Electrical Crew [40 h] | 3.77 | MEP | 5 | 1601 | CON |
| A7002 |  | Installation of Central Battery Equipment | 6d | 2019-05-19 | 2019-05-25 | A6612, A6992 | 200.75d | 21d | Electrical Crew [60 h] | 5.66 | MEP | 5 |  |  |
| A7012 |  | Installation of Disconnect Switch | 8d | 2019-05-19 | 2019-05-26 | A6612, A6992 | 198.75d | 19d | Electrical Crew [80 h] | 7.54 | MEP | 5 |  |  |
| A7032 |  | Installation of Switch Boards (MDB, EMDB) | 15d | 2019-05-19 | 2019-06-02 | A6612, A6992 | 172.25d | 0d | Electrical Crew [150 h] | 14.15 | MEP | 5 |  |  |
| A7042 |  | Installation of Panel Boards | 15d | 2019-05-19 | 2019-06-02 | A6612, A6992 | 172.25d | 0d | Electrical Crew [150 h] | 14.15 | MEP | 5 |  |  |
| A7062 |  | Installation of MCC | 15d | 2019-05-19 | 2019-06-02 | A6612, A6992 | 172.25d | 0d | Electrical Crew [150 h] | 14.15 | MEP | 5 |  |  |
| A7072 |  | Installation of Lighting Control System | 12d | 2019-05-19 | 2019-05-30 | A6612, A6992 | 175.25d | 3d | Electrical Crew [120 h] | 11.32 | MEP | 5 |  |  |
| A7022 |  | Installation of Wiring Devices and Outlets | 12d | 2019-06-02 | 2019-06-17 | A6992, A7062, A7042, A7032, A7072 | 172.25d | 0d | Electrical Crew [120 h] | 11.32 | MEP | 5 |  |  |

| ID | WBS | Activity | Duration | Start | Finish | Predecessors | Total float | Free float | Resources | Cost | Discipline | AREA | MSP Activity ID | MEP-Phase |
| --- | --- | --- | --- | --- | --- | --- | --- | --- | --- | --- | --- | --- | --- | --- |
|  | 1.4.1.4.1.1.4.1.3.-2 | **Elec._Final Fix** |  | 2019-06-02 | 2019-07-01 |  |  |  |  |  |  |  |  |  |
| A7082 |  | Panel Board Termination | 8d | 2019-06-02 | 2019-06-12 | A7032, A7042, A7062 | 189.75d | 10d | Electrical Crew [80 h] | 7.54 | MEP | 5 |  |  |
| A6652 |  | Wiring devices Termination | 6d | 2019-06-17 | 2019-06-22 | A7002, A7012, A7052, A7072, A7022, A6622 | 179.75d | 0d | Electrical Crew [60 h] | 5.66 | MEP | 5 | 1617 | CON |
| A6642 |  | Lighting Fixtures Installation and Termination | 10d | 2019-06-23 | 2019-07-01 | A6612, A6992, A7082, A6652 | 179.75d | 165.25d | Electrical Crew [100 h] | 9.43 | MEP | 5 | 1616 | CON |
|  | 1.4.1.4.1.1.4.1.4 | **FIRE FIGHTING SYSTEM** |  | 2019-03-09 | 2019-06-12 |  |  |  |  |  |  |  |  |  |
|  | 1.4.1.4.1.1.4.1.4.1. | **1st Fix** |  | 2019-03-09 | 2019-04-18 |  |  |  |  |  |  |  |  |  |
| A6742 |  | Fire Fighting Hangers & Supports | 15d | 2019-03-09 | 2019-03-21 | RM02 | 201.25d | 0d | Fire Fighting Crew [150 h] | 14.15 | MEP | 5 | 1622 | CON |
| A6712 |  | Pipe Installation | 30d | 2019-03-23 | 2019-04-18 | A6742 | 201.25d | 0d | FIRE FIGHTING [180 h]; FF pipe [103 Limt] | 16.97 | MEP | 5 | 1625 | CON |
|  | 1.4.1.4.1.1.4.1.4.-1 | **2nd Fix** |  | 2019-04-20 | 2019-05-16 |  |  |  |  |  |  |  |  |  |
| A6722 |  | Valve and Accessories Installation | 20d | 2019-04-20 | 2019-05-07 | A6712, A6742 | 201.25d | 0d | Fire Fighting Crew [200 h] | 18.86 | MEP | 5 | 1627 | CON |
| A6732 |  | Leak Test | 10d | 2019-05-08 | 2019-05-16 | A6722 | 201.25d | 0d | Fire Fighting Crew [100 h] | 9.43 | MEP | 5 | 1631 | CON |
|  | 1.4.1.4.1.1.4.1.4.-2 | **FF_Final Fix** |  | 2019-05-18 | 2019-06-12 |  |  |  |  |  |  |  |  |  |
| A6752 |  | Installation of Sprinklers | 15d | 2019-05-18 | 2019-05-30 | A6712, A6722, A6732 | 209.75d | 0d | Fire Fighting Crew [150 h] | 14.15 | MEP | 5 | 1633 | CON |
| A6762 |  | Instalaltion of Fire Extinguisher | 10d | 2019-06-01 | 2019-06-12 | A6712, A6752, A7092 FF | 264.75d | 265.25d | Fire Fighting Crew [100 h] | 9.43 | MEP | 5 |  | CON |
| A7092 |  | Installation of Fire hose Cabinet | 5d | 2019-06-01 | 2019-06-08 | A6712, A6752 | 269.75d | 5d | Fire Fighting Crew [50 h] | 4.71 | MEP | 5 |  |  |
|  | 4 | **B07 - UNDER PLATFORM ZONE 11** |  | 2019-03-09 | 2019-07-01 |  |  |  |  |  |  |  |  |  |
|  | 1.4.1.4.1.1.4.1.1 | **HVAC SYSTEM** |  | 2019-03-09 | 2019-05-04 |  |  |  |  |  |  |  |  |  |
|  | 1.4.1.4.1.1.4.1.1.1. | **1st Fix** |  | 2019-03-09 | 2019-03-25 |  |  |  |  |  |  |  |  |  |
| A8862 |  | Hanger and support Installation - Duct | 6d | 2019-03-09 | 2019-03-13 | RM02 | 238.25d | 0d | Mechanical Crew [60 h] | 5.66 | MEP | 5 | 1546 | CON |
| A8932 |  | Hanger and support Installation - CHW | 6d | 2019-03-09 | 2019-03-13 | A8862 SS | 238.25d | 0d | Mechanical Crew [60 h] | 5.66 | MEP | 5 |  |  |
| A8842 |  | Duct Installation | 12d | 2019-03-10 | 2019-03-21 | A8862 SS+2d | 247.75d | 0d | Duct Installation [130 Sqmt]; HVAC [390 h] | 36.78 | MEP | 5 | 1549 | CON |
| A8852 |  | Duct Insulation | 8d | 2019-03-13 | 2019-03-20 | A8842 SS+3d | 271.75d | 33d | Duct Insulation [145 Sqmt]; HVAC [90 h] | 8.49 | MEP | 5 | 1552 | CON |
| A8952 |  | Chilled Water Piping Installation | 12d | 2019-03-13 | 2019-03-25 | A8932 | 238.25d | 0d | Mechanical Crew [120 h] | 11.32 | MEP | 5 |  |  |
|  | 1.4.1.4.1.1.4.1.1.-1 | **2nd Fix** |  | 2019-03-21 | 2019-04-13 |  |  |  |  |  |  |  |  |  |
| A8942 |  | Installation of Duct Accessories (VD, FD, MSD etc....) | 12d | 2019-03-21 | 2019-04-01 | A8842 | 258.75d | 20d | Mechanical Crew [120 h] | 11.32 | MEP | 5 |  |  |
| A9042 |  | CRAC Units Installation | 15d | 2019-03-21 | 2019-04-04 | A8842 | 247.75d | 9d | Mechanical Crew [150 h] | 14.15 | MEP | 5 |  |  |
| A9052 |  | FCU Installation | 15d | 2019-03-21 | 2019-04-04 | A8842 | 247.75d | 9d | Mechanical Crew [150 h] | 14.15 | MEP | 5 |  |  |
| A9062 |  | VRF DX Units Installation | 12d | 2019-03-21 | 2019-04-01 | A8842 | 250.75d | 12d | Mechanical Crew [120 h] | 11.32 | MEP | 5 |  |  |
| A9072 |  | Installation of Attenuators | 10d | 2019-03-21 | 2019-03-31 | A8842 | 252.75d | 14d | Mechanical Crew [100 h] | 9.43 | MEP | 5 |  |  |
| A9082 |  | Installation of HVAC Fans | 10d | 2019-03-21 | 2019-03-31 | A8842 | 252.75d | 14d | Mechanical Crew [100 h] | 9.43 | MEP | 5 |  |  |
| A9102 |  | Pressurization Unit | 8d | 2019-03-21 | 2019-03-28 | A8842 | 254.75d | 16d | Mechanical Crew [80 h] | 7.54 | MEP | 5 |  |  |
| A9112 |  | Dosing pot | 5d | 2019-03-21 | 2019-03-26 | A8842 | 257.75d | 19d | Mechanical Crew [50 h] | 4.71 | MEP | 5 |  |  |
| A9132 |  | Air Handling Units Installation | 12d | 2019-03-21 | 2019-04-01 | A8842 | 250.75d | 12d | Mechanical Crew [120 h] | 11.32 | MEP | 5 |  |  |
| A8972 |  | Valves and Accessories | 10d | 2019-03-25 | 2019-04-03 | A8952 | 238.25d | 0d | Mechanical Crew [100 h] | 9.43 | MEP | 5 |  |  |
| A9092 |  | Air-Cooled Chillers | 15d | 2019-03-25 | 2019-04-08 | A8952 | 243.75d | 5d | Mechanical Crew [150 h] | 14.15 | MEP | 5 |  |  |
| A9142 |  | Chilled Water Pump Installation | 12d | 2019-03-25 | 2019-04-04 | A8952 | 246.75d | 8d | Mechanical Crew [120 h] | 11.32 | MEP | 5 |  |  |
| A8982 |  | Chilled Water Pipe Insulation and Cladding | 10d | 2019-04-03 | 2019-04-13 | A8952, A8972 | 238.25d | 0d | Mechanical Crew [100 h] | 9.43 | MEP | 5 |  |  |

| ID | WBS | Activity | Duration | Start | Finish | Predecessors | Total float | Free float | Resources | Cost | Discipline | AREA | MSP Activity ID | MEP-Phase |
| --- | --- | --- | --- | --- | --- | --- | --- | --- | --- | --- | --- | --- | --- | --- |
|  | 1.4.1.4.1.1.4.1.1.-2 | **HVAC_Final Fix** |  | 2019-04-13 | 2019-05-04 |  |  |  |  |  |  |  |  |  |
| A9122 |  | Equuipment Connection | 8d | 2019-04-13 | 2019-04-20 | A9142, A9132, A9092, A9082, A9072, A9042, A9052, A9062, A9112, A9102, A8982 | 238.75d | 0d | Mechanical Crew [80 h] | 7.54 | MEP | 5 |  |  |
| A8962 |  | Air Outlets (Grills, Diffusers, Registers etc...) | 15d | 2019-04-20 | 2019-05-04 | A8942, A8842, A8852, A9122 | 238.75d | 229.25d | Mechanical Crew [150 h] | 14.15 | MEP | 5 |  |  |
|  | 1.4.1.4.1.1.4.1.2 | **PLUMBING SYSTEM** |  | 2019-03-09 | 2019-04-18 |  |  |  |  |  |  |  |  |  |
|  | 1.4.1.4.1.1.4.1.2.1. | **1st Fix** |  | 2019-03-09 | 2019-04-01 |  |  |  |  |  |  |  |  |  |
| A8722 |  | Hanger and support Installation | 10d | 2019-03-09 | 2019-03-17 | RM02 | 234.25d | 0d | Plumbing Crew [100 h] | 9.43 | MEP | 5 | 1566 | CON |
| A8762 |  | Drainage and Vent Pipe & Fittings | 20d | 2019-03-13 | 2019-03-31 | A8722 SS+5d | 267.75d | 1d | Plumbing Crew [200 h] | 18.86 | MEP | 5 | 1573 | CON |
| A8732 |  | Domestic Water Pipe & Fittings | 20d | 2019-03-13 | 2019-04-01 | A8722 SS+6d | 234.25d | 0d | Plumbing Crew [200 h] | 18.86 | MEP | 5 | 1570 | CON |
|  | 1.4.1.4.1.1.4.1.2.-1 | **2nd Fix** |  | 2019-04-01 | 2019-04-16 |  |  |  |  |  |  |  |  |  |
| A8742 |  | Domestic Water Valves | 12d | 2019-04-01 | 2019-04-13 | A8732 | 234.25d | 0d | Plumbing Crew [120 h] | 11.32 | MEP | 5 | 1571 | CON |
| A9002 |  | Sewege Pumps Installation | 5d | 2019-04-01 | 2019-04-06 | A8762, A8732 | 266.75d | 11d | Plumbing Crew [50 h] | 4.71 | MEP | 5 |  |  |
| A8752 |  | Leak Test | 4d | 2019-04-13 | 2019-04-16 | A8742 | 234.25d | 0d | Plumbing Crew [40 h] | 3.77 | MEP | 5 | 1572 | CON |
|  | 1.4.1.4.1.1.4.1.2.-2 | **PLM_Final Fix** |  | 2019-04-16 | 2019-04-18 |  |  |  |  |  |  |  |  |  |
| A8992 |  | Water Heaters | 2d | 2019-04-16 | 2019-04-18 | A8752, A8762, A8732 | 255.75d | 0d | Plumbing Crew [20 h] | 1.89 | MEP | 5 |  |  |
| A9012 |  | Floor Drain | 2d | 2019-04-16 | 2019-04-18 | A8992 SS | 255.75d | 0d | Plumbing Crew [20 h] | 1.89 | MEP | 5 |  |  |
| A9022 |  | Wash Basin / Water Closet | 2d | 2019-04-16 | 2019-04-18 | A9012 SS | 255.75d | 0d | Plumbing Crew [20 h] | 1.89 | MEP | 5 |  |  |
| A9032 |  | Eye Wash | 2d | 2019-04-16 | 2019-04-18 | A9022 SS, A9002 | 255.75d | 233.25d | Plumbing Crew [20 h] | 1.89 | MEP | 5 |  |  |
|  | 1.4.1.4.1.1.4.1.3 | **ELECTRICAL / CONTROLS** |  | 2019-03-09 | 2019-07-01 |  |  |  |  |  |  |  |  |  |
|  | 1.4.1.4.1.1.4.1.3.1. | **1st Fix** |  | 2019-03-09 | 2019-04-03 |  |  |  |  |  |  |  |  |  |
| A8822 |  | Installation of Conduits and Boxes | 12d | 2019-03-09 | 2019-03-19 | RM02 | 172.25d | 0d | Electrical Crew [120 h] | 11.32 | MEP | 5 | 1592 | CON |
| A8832 |  | Installation of Cable Tray, Ladder and Trunk | 20d | 2019-03-16 | 2019-04-03 | A8822 SS+8d | 235.75d | 0d | Electrical Crew [200 h] | 18.86 | MEP | 5 | 1593 | CON |
|  | 1.4.1.4.1.1.4.1.3.-1 | **2nd Fix** |  | 2019-03-19 | 2019-06-17 |  |  |  |  |  |  |  |  |  |
| A8792 |  | Grounding and Bonding Installation | 20d | 2019-03-19 | 2019-04-07 | A8822 | 172.25d | 0d | Electrical Crew [200 h] | 18.86 | MEP | 5 | 1596 | CON |
| A9212 |  | Installation of Bus Duct System | 20d | 2019-04-03 | 2019-04-22 | A8832 | 235.75d | 56d | Electrical Crew [200 h] | 18.86 | MEP | 5 |  |  |
| A9152 |  | Wire Pulling | 20d | 2019-04-07 | 2019-04-25 | A8792 | 172.25d | 0d | Electrical Crew [200 h] | 18.86 | MEP | 5 |  |  |
| A8772 |  | Power Cable Laying | 25d | 2019-04-25 | 2019-05-19 | A9152, A8792 | 172.25d | 0d | Electrical Crew [250 h] | 23.58 | MEP | 5 | 1600 | CON |
| A8782 |  | Continuity Test - Power Cables | 4d | 2019-05-19 | 2019-05-22 | A8772 | 202.75d | 23d | Electrical Crew [40 h] | 3.77 | MEP | 5 | 1601 | CON |
| A9162 |  | Installation of Central Battery Equipment | 6d | 2019-05-19 | 2019-05-25 | A8772, A9152 | 200.75d | 21d | Electrical Crew [60 h] | 5.66 | MEP | 5 |  |  |
| A9172 |  | Installation of Disconnect Switch | 8d | 2019-05-19 | 2019-05-26 | A8772, A9152 | 198.75d | 19d | Electrical Crew [80 h] | 7.54 | MEP | 5 |  |  |
| A9192 |  | Installation of Switch Boards (MDB, EMDB) | 15d | 2019-05-19 | 2019-06-02 | A8772, A9152 | 172.25d | 0d | Electrical Crew [150 h] | 14.15 | MEP | 5 |  |  |
| A9202 |  | Installation of Panel Boards | 15d | 2019-05-19 | 2019-06-02 | A8772, A9152 | 172.25d | 0d | Electrical Crew [150 h] | 14.15 | MEP | 5 |  |  |
| A9222 |  | Installation of MCC | 15d | 2019-05-19 | 2019-06-02 | A8772, A9152 | 172.25d | 0d | Electrical Crew [150 h] | 14.15 | MEP | 5 |  |  |
| A9232 |  | Installation of Lighting Control System | 12d | 2019-05-19 | 2019-05-30 | A8772, A9152 | 175.25d | 3d | Electrical Crew [120 h] | 11.32 | MEP | 5 |  |  |
| A9182 |  | Installation of Wiring Devices and Outlets | 12d | 2019-06-02 | 2019-06-17 | A9152, A9222, A9202, A9192, A9232 | 172.25d | 0d | Electrical Crew [120 h] | 11.32 | MEP | 5 |  |  |

| ID | WBS | Activity | Type | Duration | Start | Finish | Predecessors | Total float | Free float | Calendar | Resources | Cost | Discipline | AREA | MSP Activity ID | MEP-Phase |
| --- | --- | --- | --- | --- | --- | --- | --- | --- | --- | --- | --- | --- | --- | --- | --- | --- |
|  | 1.4.1.4.1.1.4.1.3.-2 | **Elec._Final Fix** |  |  | 2019-06-02 | 2019-07-01 |  |  |  |  |  |  |  |  |  |  |
| A9242 |  | Panel Board Termination |  | 8d | 2019-06-02 | 2019-06-12 | A9192, A9202, A9222 | 189.75d | 10d |  | Electrical Crew [80 h] | 7.54 | MEP | 5 |  |  |
| A8812 |  | Wiring devices Termination |  | 6d | 2019-06-17 | 2019-06-22 | A9162, A9172, A9212, A9232, A9182, A8782 | 179.75d | 0d |  | Electrical Crew [60 h] | 5.66 | MEP | 5 | 1617 | CON |
| A8802 |  | Lighting Fixtures Installation and Termination |  | 10d | 2019-06-23 | 2019-07-01 | A8772, A9152, A9242, A8812 | 179.75d | 165.25d |  | Electrical Crew [100 h] | 9.43 | MEP | 5 | 1616 | CON |
|  | 1.4.1.4.1.1.4.1.4 | **FIRE FIGHTING SYSTEM** |  |  | 2019-03-09 | 2019-06-12 |  |  |  |  |  |  |  |  |  |  |
|  | 1.4.1.4.1.1.4.1.4.1. | **1st Fix** |  |  | 2019-03-09 | 2019-04-18 |  |  |  |  |  |  |  |  |  |  |
| A8902 |  | Fire Fighting Hangers & Supports |  | 15d | 2019-03-09 | 2019-03-21 | RM02 | 201.25d | 0d |  | Fire Fighting Crew [150 h] | 14.15 | MEP | 5 | 1622 | CON |
| A8872 |  | Pipe Installation |  | 30d | 2019-03-23 | 2019-04-18 | A8902 | 201.25d | 0d |  | FF pipe [103 Limt]; FIRE FIGHTING [180 h] | 16.97 | MEP | 5 | 1625 | CON |
|  | 1.4.1.4.1.1.4.1.4.-1 | **2nd Fix** |  |  | 2019-04-20 | 2019-05-16 |  |  |  |  |  |  |  |  |  |  |
| A8882 |  | Valve and Accessories Installation |  | 20d | 2019-04-20 | 2019-05-07 | A8872, A8902 | 201.25d | 0d |  | Fire Fighting Crew [200 h] | 18.86 | MEP | 5 | 1627 | CON |
| A8892 |  | Leak Test |  | 10d | 2019-05-08 | 2019-05-16 | A8882 | 201.25d | 0d |  | Fire Fighting Crew [100 h] | 9.43 | MEP | 5 | 1631 | CON |
|  | 1.4.1.4.1.1.4.1.4.-2 | **FF_Final Fix** |  |  | 2019-05-18 | 2019-06-12 |  |  |  |  |  |  |  |  |  |  |
| A8912 |  | Installation of Sprinklers |  | 15d | 2019-05-18 | 2019-05-30 | A8872, A8882, A8892 | 209.75d | 0d |  | Fire Fighting Crew [150 h] | 14.15 | MEP | 5 | 1633 | CON |
| A8922 |  | Instalaltion of Fire Extinguisher |  | 10d | 2019-06-01 | 2019-06-12 | A8872, A8912, A9252 FF | 264.75d | 265.25d |  | Fire Fighting Crew [100 h] | 9.43 | MEP | 5 |  | CON |
| A9252 |  | Installation of Fire hose Cabinet |  | 5d | 2019-06-01 | 2019-06-08 | A8872, A8912 | 269.75d | 5d |  | Fire Fighting Crew [50 h] | 4.71 | MEP | 5 |  |  |
|  | 1 | **CENTRAL UNDER PLATFORM ZONE (5 TO 7)** |  |  | 2019-05-29 | 2019-09-26 |  |  |  |  |  |  |  |  |  |  |
| LOE-SUM3-030 |  | Central . B07 - MEP Works; 1st & 2nd Fix | level of effort | 111.5d | 2019-05-29 | 2019-09-10 | RM03 | 78.75d | 0d | Saudi |  |  | MEP |  |  |  |
| LOE-SUM3-040 |  | Central . B07 - MEP Works; Final Fix | level of effort | 87.25d | 2019-07-07 | 2019-09-26 | A11282 SS | 92.25d | 0d | Saudi |  |  | MEP |  |  |  |
|  | 2 | **B07 - UNDER PLATFORM ZONE 05** |  |  | 2019-05-29 | 2019-09-26 |  |  |  |  |  |  |  |  |  |  |
|  | 1.4.1.4.1.1.4.1.1 | **HVAC SYSTEM** |  |  | 2019-05-29 | 2019-07-28 |  |  |  |  |  |  |  |  |  |  |
|  | 1.4.1.4.1.1.4.1.1.1. | **1st Fix** |  |  | 2019-05-29 | 2019-06-18 |  |  |  |  |  |  |  |  |  |  |
| A11022 |  | Hanger and support Installation - Duct |  | 6d | 2019-05-29 | 2019-06-03 | RM03 | 143.25d | 0d |  | Mechanical Crew [60 h] | 5.66 | MEP | 3 | 1546 | CON |
| A11092 |  | Hanger and support Installation - CHW |  | 6d | 2019-05-29 | 2019-06-03 | A11022 SS | 143.25d | 0d |  | Mechanical Crew [60 h] | 5.66 | MEP | 3 |  |  |
| A11002 |  | Duct Installation |  | 12d | 2019-05-30 | 2019-06-15 | A11022 SS+2d | 160.25d | 0d |  | Duct Installation [174 Sqmt]; HVAC [520 h] | 49.04 | MEP | 3 | 1549 | CON |
| A11012 |  | Duct Insulation |  | 8d | 2019-06-03 | 2019-06-13 | A11002 SS+3d | 184.25d | 33d |  | Duct Insulation [180 Sqmt]; HVAC [128 h] | 12.07 | MEP | 3 | 1552 | CON |
| A11112 |  | Chilled Water Piping Installation |  | 12d | 2019-06-03 | 2019-06-18 | A11092 | 143.25d | 0d |  | Mechanical Crew [120 h] | 11.32 | MEP | 3 |  |  |

| ID | WBS | Activity | Duration | Start | Finish | Predecessors | Total float | Free float | Resources | Cost | Discipline | AREA | MSP Activity ID | MEP-Phase |
| --- | --- | --- | --- | --- | --- | --- | --- | --- | --- | --- | --- | --- | --- | --- |
|  | 1.4.1.4.1.1.4.1.1.-1 | **2nd Fix** |  | 2019-06-15 | 2019-07-07 |  |  |  |  |  |  |  |  |  |
| A11102 |  | Installation of Duct Accessories (VD, FD, MSD etc....) | 12d | 2019-06-15 | 2019-06-25 | A11002 | 171.25d | 20d | Mechanical Crew [120 h] | 11.32 | MEP | 3 |  |  |
| A11202 |  | CRAC Units Installation | 15d | 2019-06-15 | 2019-06-29 | A11002 | 160.25d | 9d | Mechanical Crew [150 h] | 14.15 | MEP | 3 |  |  |
| A11212 |  | FCU Installation | 15d | 2019-06-15 | 2019-06-29 | A11002 | 160.25d | 9d | Mechanical Crew [150 h] | 14.15 | MEP | 3 |  |  |
| A11222 |  | VRF DX Units Installation | 12d | 2019-06-15 | 2019-06-25 | A11002 | 163.25d | 12d | Mechanical Crew [120 h] | 11.32 | MEP | 3 |  |  |
| A11232 |  | Installation of Attenuators | 10d | 2019-06-15 | 2019-06-24 | A11002 | 165.25d | 14d | Mechanical Crew [100 h] | 9.43 | MEP | 3 |  |  |
| A11242 |  | Installation of HVAC Fans | 10d | 2019-06-15 | 2019-06-24 | A11002 | 165.25d | 14d | Mechanical Crew [100 h] | 9.43 | MEP | 3 |  |  |
| A11262 |  | Pressurization Unit | 8d | 2019-06-15 | 2019-06-22 | A11002 | 167.25d | 16d | Mechanical Crew [80 h] | 7.54 | MEP | 3 |  |  |
| A11272 |  | Dosing pot | 5d | 2019-06-15 | 2019-06-19 | A11002 | 170.25d | 19d | Mechanical Crew [50 h] | 4.71 | MEP | 3 |  |  |
| A11292 |  | Air Handling Units Installation | 12d | 2019-06-15 | 2019-06-25 | A11002 | 163.25d | 12d | Mechanical Crew [120 h] | 11.32 | MEP | 3 |  |  |
| A11132 |  | Valves and Accessories | 10d | 2019-06-18 | 2019-06-27 | A11112 | 143.25d | 0d | Mechanical Crew [100 h] | 9.43 | MEP | 3 |  |  |
| A11252 |  | Air-Cooled Chillers | 15d | 2019-06-18 | 2019-07-02 | A11112 | 156.25d | 5d | Mechanical Crew [150 h] | 14.15 | MEP | 3 |  |  |
| A11302 |  | Chilled Water Pump Installation | 12d | 2019-06-18 | 2019-06-29 | A11112 | 159.25d | 8d | Mechanical Crew [120 h] | 11.32 | MEP | 3 |  |  |
| A11142 |  | Chilled Water Pipe Insulation and Cladding | 10d | 2019-06-27 | 2019-07-07 | A11112, A11132 | 143.25d | 0d | Mechanical Crew [100 h] | 9.43 | MEP | 3 |  |  |
|  | 1.4.1.4.1.1.4.1.1.-2 | **HVAC_Final Fix** |  | 2019-07-07 | 2019-07-28 |  |  |  |  |  |  |  |  |  |
| A11282 |  | Equuipment Connection | 8d | 2019-07-07 | 2019-07-14 | A11302, A11292, A11252, A11242, A11232, A11202, A11212, A11222, A11272, A11262, A11142 | 151.25d | 0d | Mechanical Crew [80 h] | 7.54 | MEP | 3 |  |  |
| A11122 |  | Air Outlets (Grills, Diffusers, Registers etc...) | 15d | 2019-07-14 | 2019-07-28 | A11102, A11002, A11012, A11282 | 151.25d | 141.75d | Mechanical Crew [150 h] | 14.15 | MEP | 3 |  |  |
|  | 1.4.1.4.1.1.4.1.2 | **PLUMBING SYSTEM** |  | 2019-05-29 | 2019-07-13 |  |  |  |  |  |  |  |  |  |
|  | 1.4.1.4.1.1.4.1.2.1. | **1st Fix** |  | 2019-05-29 | 2019-06-25 |  |  |  |  |  |  |  |  |  |
| A10882 |  | Hanger and support Installation | 10d | 2019-05-29 | 2019-06-10 | RM03 | 139.25d | 0d | Plumbing Crew [100 h] | 9.43 | MEP | 3 | 1566 | CON |
| A10922 |  | Drainage and Vent Pipe & Fittings | 20d | 2019-06-03 | 2019-06-24 | A10882 SS+5d | 180.25d | 1d | Plumbing Crew [200 h] | 18.86 | MEP | 3 | 1573 | CON |
| A10892 |  | Domestic Water Pipe & Fittings | 20d | 2019-06-03 | 2019-06-25 | A10882 SS+6d | 139.25d | 0d | Plumbing Crew [200 h] | 18.86 | MEP | 3 | 1570 | CON |
|  | 1.4.1.4.1.1.4.1.2.-1 | **2nd Fix** |  | 2019-06-25 | 2019-07-10 |  |  |  |  |  |  |  |  |  |
| A10902 |  | Domestic Water Valves | 12d | 2019-06-25 | 2019-07-07 | A10892 | 139.25d | 0d | Plumbing Crew [120 h] | 11.32 | MEP | 3 | 1571 | CON |
| A11162 |  | Sewege Pumps Installation | 5d | 2019-06-25 | 2019-06-30 | A10922, A10892 | 179.25d | 11d | Plumbing Crew [50 h] | 4.71 | MEP | 3 |  |  |
| A10912 |  | Leak Test | 4d | 2019-07-07 | 2019-07-10 | A10902 | 139.25d | 0d | Plumbing Crew [40 h] | 3.77 | MEP | 3 | 1572 | CON |

| ID | WBS | Activity | Duration | Start | Finish | Predecessors | Total float | Free float | Resources | Cost | Discipline | AREA | MSP Activity ID | MEP-Phase |
| --- | --- | --- | --- | --- | --- | --- | --- | --- | --- | --- | --- | --- | --- | --- |
|  | 1.4.1.4.1.1.4.1.2.-2 | **PLM_Final Fix** |  | 2019-07-10 | 2019-07-13 |  |  |  |  |  |  |  |  |  |
| A11152 |  | Water Heaters | 2d | 2019-07-10 | 2019-07-13 | A10912, A10922, A10892 | 168.25d | 0d | Plumbing Crew [20 h] | 1.89 | MEP | 3 |  |  |
| A11172 |  | Floor Drain | 2d | 2019-07-10 | 2019-07-13 | A11152 SS | 168.25d | 0d | Plumbing Crew [20 h] | 1.89 | MEP | 3 |  |  |
| A11182 |  | Wash Basin / Water Closet | 2d | 2019-07-10 | 2019-07-13 | A11172 SS | 168.25d | 0d | Plumbing Crew [20 h] | 1.89 | MEP | 3 |  |  |
| A11192 |  | Eye Wash | 2d | 2019-07-10 | 2019-07-13 | A11182 SS, A11162 | 168.25d | 145.75d | Plumbing Crew [20 h] | 1.89 | MEP | 3 |  |  |
|  | 1.4.1.4.1.1.4.1.3 | **ELECTRICAL / CONTROLS** |  | 2019-05-29 | 2019-09-26 |  |  |  |  |  |  |  |  |  |
|  | 1.4.1.4.1.1.4.1.3.1. | **1st Fix** |  | 2019-05-29 | 2019-06-27 |  |  |  |  |  |  |  |  |  |
| A10982 |  | Installation of Conduits and Boxes | 12d | 2019-05-29 | 2019-06-12 | RM03 | 77.25d | 0d | Electrical Crew [120 h] | 11.32 | MEP | 3 | 1592 | CON |
| A10992 |  | Installation of Cable Tray, Ladder and Trunk | 20d | 2019-06-09 | 2019-06-27 | A10982 SS+8d | 148.25d | 0d | Electrical Crew [200 h] | 18.86 | MEP | 3 | 1593 | CON |
|  | 1.4.1.4.1.1.4.1.3.-1 | **2nd Fix** |  | 2019-06-12 | 2019-09-10 |  |  |  |  |  |  |  |  |  |
| A10952 |  | Grounding and Bonding Installation | 20d | 2019-06-12 | 2019-07-01 | A10982 | 77.25d | 0d | Electrical Crew [200 h] | 18.86 | MEP | 3 | 1596 | CON |
| A11372 |  | Installation of Bus Duct System | 20d | 2019-06-27 | 2019-07-16 | A10992 | 148.25d | 56d | Electrical Crew [200 h] | 18.86 | MEP | 3 |  |  |
| A11312 |  | Wire Pulling | 20d | 2019-07-01 | 2019-07-20 | A10952 | 77.25d | 0d | Electrical Crew [200 h] | 18.86 | MEP | 3 |  |  |
| A10932 |  | Power Cable Laying | 25d | 2019-07-20 | 2019-08-15 | A11312, A10952 | 77.25d | 0d | Electrical Crew [250 h] | 23.58 | MEP | 3 | 1600 | CON |
| A10942 |  | Continuity Test - Power Cables | 4d | 2019-08-15 | 2019-08-19 | A10932 | 115.25d | 23d | Electrical Crew [40 h] | 3.77 | MEP | 3 | 1601 | CON |
| A11322 |  | Installation of Central Battery Equipment | 6d | 2019-08-15 | 2019-08-21 | A10932, A11312 | 113.25d | 21d | Electrical Crew [60 h] | 5.66 | MEP | 3 |  |  |
| A11332 |  | Installation of Disconnect Switch | 8d | 2019-08-15 | 2019-08-22 | A10932, A11312 | 111.25d | 19d | Electrical Crew [80 h] | 7.54 | MEP | 3 |  |  |
| A11352 |  | Installation of Switch Boards (MDB, EMDB) | 15d | 2019-08-15 | 2019-08-29 | A10932, A11312 | 77.25d | 0d | Electrical Crew [150 h] | 14.15 | MEP | 3 |  |  |
| A11362 |  | Installation of Panel Boards | 15d | 2019-08-15 | 2019-08-29 | A10932, A11312 | 77.25d | 0d | Electrical Crew [150 h] | 14.15 | MEP | 3 |  |  |
| A11382 |  | Installation of MCC | 15d | 2019-08-15 | 2019-08-29 | A10932, A11312 | 77.25d | 0d | Electrical Crew [150 h] | 14.15 | MEP | 3 |  |  |
| A11392 |  | Installation of Lighting Control System | 12d | 2019-08-15 | 2019-08-27 | A10932, A11312 | 80.25d | 3d | Electrical Crew [120 h] | 11.32 | MEP | 3 |  |  |
| A11342 |  | Installation of Wiring Devices and Outlets | 12d | 2019-08-29 | 2019-09-10 | A11312, A11382, A11362, A11352, A11392 | 77.25d | 0d | Electrical Crew [120 h] | 11.32 | MEP | 3 |  |  |
|  | 1.4.1.4.1.1.4.1.3.-2 | **Elec._Final Fix** |  | 2019-08-29 | 2019-09-26 |  |  |  |  |  |  |  |  |  |
| A11402 |  | Panel Board Termination | 8d | 2019-08-29 | 2019-09-05 | A11352, A11362, A11382 | 102.25d | 10d | Electrical Crew [80 h] | 7.54 | MEP | 3 |  |  |
| A10972 |  | Wiring devices Termination | 6d | 2019-09-10 | 2019-09-15 | A11322, A11332, A11372, A11392, A11342, A10942 | 92.25d | 0d | Electrical Crew [60 h] | 5.66 | MEP | 3 | 1617 | CON |
| A10962 |  | Lighting Fixtures Installation and Termination | 10d | 2019-09-16 | 2019-09-26 | A10932, A11312, A11402, A10972, LOE-SUM3-040 FF | 92.25d | 77.75d | Electrical Crew [100 h] | 9.43 | MEP | 3 | 1616 | CON |

| ID | WBS | Activity | Duration | Start | Finish | Predecessors | Total float | Free float | Resources | Cost | MSP Activity ID | Discipline | MEP-Phase | AREA |
| --- | --- | --- | --- | --- | --- | --- | --- | --- | --- | --- | --- | --- | --- | --- |
|  | 1.4.1.4.1.1.4.1.4 | **FIRE FIGHTING SYSTEM** |  | 2019-05-29 | 2019-09-05 |  |  |  |  |  |  |  |  |  |
|  | 1.4.1.4.1.1.4.1.4.1. | **1st Fix** |  | 2019-05-29 | 2019-07-13 |  |  |  |  |  |  |  |  |  |
| A11062 |  | Fire Fighting Hangers & Supports | 15d | 2019-05-29 | 2019-06-15 | RM03 | 106.25d | 0d | Fire Fighting Crew [150 h] | 14.15 | 1622 | MEP | CON | 3 |
| A11032 |  | Pipe Installation | 30d | 2019-06-16 | 2019-07-13 | A11062 | 106.25d | 0d | FIRE FIGHTING [241 h]; FF pipe [137 Limt] | 22.73 | 1625 | MEP | CON | 3 |
|  | 1.4.1.4.1.1.4.1.4.-1 | **2nd Fix** |  | 2019-07-14 | 2019-08-13 |  |  |  |  |  |  |  |  |  |
| A11042 |  | Valve and Accessories Installation | 20d | 2019-07-14 | 2019-07-31 | A11032, A11062 | 106.25d | 0d | Fire Fighting Crew [200 h] | 18.86 | 1627 | MEP | CON | 3 |
| A11052 |  | Leak Test | 10d | 2019-08-01 | 2019-08-13 | A11042 | 106.25d | 0d | Fire Fighting Crew [100 h] | 9.43 | 1631 | MEP | CON | 3 |
|  | 1.4.1.4.1.1.4.1.4.-2 | **FF_Final Fix** |  | 2019-08-14 | 2019-09-05 |  |  |  |  |  |  |  |  |  |
| A11072 |  | Installation of Sprinklers | 15d | 2019-08-14 | 2019-08-27 | A11032, A11042, A11052 | 122.25d | 0d | Fire Fighting Crew [150 h] | 14.15 | 1633 | MEP | CON | 3 |
| A11082 |  | Instalaltion of Fire Extinguisher | 10d | 2019-08-28 | 2019-09-05 | A11032, A11072, A11412 FF | 177.25d | 177.75d | Fire Fighting Crew [100 h] | 9.43 |  | MEP | CON | 3 |
| A11412 |  | Installation of Fire hose Cabinet | 5d | 2019-08-28 | 2019-09-01 | A11032, A11072 | 182.25d | 5d | Fire Fighting Crew [50 h] | 4.71 |  | MEP |  | 3 |
|  | 1 | **B07 - UNDER PLATFORM ZONE 06** |  | 2019-05-29 | 2019-09-26 |  |  |  |  |  |  |  |  |  |
|  | 1.4.1.4.1.1.4.1.1 | **HVAC SYSTEM** |  | 2019-05-29 | 2019-07-28 |  |  |  |  |  |  |  |  |  |
|  | 1.4.1.4.1.1.4.1.1.1. | **1st Fix** |  | 2019-05-29 | 2019-06-18 |  |  |  |  |  |  |  |  |  |
| A13182 |  | Hanger and support Installation - Duct | 6d | 2019-05-29 | 2019-06-03 | RM03 | 143.25d | 0d | Mechanical Crew [60 h] | 5.66 | 1546 | MEP | CON | 3 |
| A13252 |  | Hanger and support Installation - CHW | 6d | 2019-05-29 | 2019-06-03 | A13182 SS | 143.25d | 0d | Mechanical Crew [60 h] | 5.66 |  | MEP |  | 3 |
| A13162 |  | Duct Installation | 12d | 2019-05-30 | 2019-06-15 | A13182 SS+2d | 160.25d | 0d | Duct Installation [174 Sqmt]; HVAC [520 h] | 49.04 | 1549 | MEP | CON | 3 |
| A13172 |  | Duct Insulation | 8d | 2019-06-03 | 2019-06-13 | A13162 SS+3d | 184.25d | 33d | Duct Insulation [180 Sqmt]; HVAC [128 h] | 12.07 | 1552 | MEP | CON | 3 |
| A13272 |  | Chilled Water Piping Installation | 12d | 2019-06-03 | 2019-06-18 | A13252 | 143.25d | 0d | Mechanical Crew [120 h] | 11.32 |  | MEP |  | 3 |
|  | 1.4.1.4.1.1.4.1.1.-1 | **2nd Fix** |  | 2019-06-15 | 2019-07-07 |  |  |  |  |  |  |  |  |  |
| A13262 |  | Installation of Duct Accessories (VD, FD, MSD etc....) | 12d | 2019-06-15 | 2019-06-25 | A13162 | 171.25d | 20d | Mechanical Crew [120 h] | 11.32 |  | MEP |  | 3 |
| A13362 |  | CRAC Units Installation | 15d | 2019-06-15 | 2019-06-29 | A13162 | 160.25d | 9d | Mechanical Crew [150 h] | 14.15 |  | MEP |  | 3 |
| A13372 |  | FCU Installation | 15d | 2019-06-15 | 2019-06-29 | A13162 | 160.25d | 9d | Mechanical Crew [150 h] | 14.15 |  | MEP |  | 3 |
| A13382 |  | VRF DX Units Installation | 12d | 2019-06-15 | 2019-06-25 | A13162 | 163.25d | 12d | Mechanical Crew [120 h] | 11.32 |  | MEP |  | 3 |
| A13392 |  | Installation of Attenuators | 10d | 2019-06-15 | 2019-06-24 | A13162 | 165.25d | 14d | Mechanical Crew [100 h] | 9.43 |  | MEP |  | 3 |
| A13402 |  | Installation of HVAC Fans | 10d | 2019-06-15 | 2019-06-24 | A13162 | 165.25d | 14d | Mechanical Crew [100 h] | 9.43 |  | MEP |  | 3 |
| A13422 |  | Pressurization Unit | 8d | 2019-06-15 | 2019-06-22 | A13162 | 167.25d | 16d | Mechanical Crew [80 h] | 7.54 |  | MEP |  | 3 |
| A13432 |  | Dosing pot | 5d | 2019-06-15 | 2019-06-19 | A13162 | 170.25d | 19d | Mechanical Crew [50 h] | 4.71 |  | MEP |  | 3 |
| A13452 |  | Air Handling Units Installation | 12d | 2019-06-15 | 2019-06-25 | A13162 | 163.25d | 12d | Mechanical Crew [120 h] | 11.32 |  | MEP |  | 3 |
| A13292 |  | Valves and Accessories | 10d | 2019-06-18 | 2019-06-27 | A13272 | 143.25d | 0d | Mechanical Crew [100 h] | 9.43 |  | MEP |  | 3 |
| A13412 |  | Air-Cooled Chillers | 15d | 2019-06-18 | 2019-07-02 | A13272 | 156.25d | 5d | Mechanical Crew [150 h] | 14.15 |  | MEP |  | 3 |
| A13462 |  | Chilled Water Pump Installation | 12d | 2019-06-18 | 2019-06-29 | A13272 | 159.25d | 8d | Mechanical Crew [120 h] | 11.32 |  | MEP |  | 3 |
| A13302 |  | Chilled Water Pipe Insulation and Cladding | 10d | 2019-06-27 | 2019-07-07 | A13272, A13292 | 143.25d | 0d | Mechanical Crew [100 h] | 9.43 |  | MEP |  | 3 |

| ID | WBS | Activity | Duration | Start | Finish | Predecessors | Total float | Free float | Resources | Cost | Discipline | AREA | MSP Activity ID | MEP-Phase |
| --- | --- | --- | --- | --- | --- | --- | --- | --- | --- | --- | --- | --- | --- | --- |
|  | 1.4.1.4.1.1.4.1.1.-2 | **HVAC_Final Fix** |  | 2019-07-07 | 2019-07-28 |  |  |  |  |  |  |  |  |  |
| A13442 |  | Equuipment Connection | 8d | 2019-07-07 | 2019-07-14 | A13462, A13452, A13412, A13402, A13392, A13362, A13372, A13382, A13432, A13422, A13302 | 151.25d | 0d | Mechanical Crew [80 h] | 7.54 | MEP | 3 |  |  |
| A13282 |  | Air Outlets (Grills, Diffusers, Registers etc...) | 15d | 2019-07-14 | 2019-07-28 | A13262, A13162, A13172, A13442 | 151.25d | 141.75d | Mechanical Crew [150 h] | 14.15 | MEP | 3 |  |  |
|  | 1.4.1.4.1.1.4.1.2 | **PLUMBING SYSTEM** |  | 2019-05-29 | 2019-07-13 |  |  |  |  |  |  |  |  |  |
|  | 1.4.1.4.1.1.4.1.2.1. | **1st Fix** |  | 2019-05-29 | 2019-06-25 |  |  |  |  |  |  |  |  |  |
| A13042 |  | Hanger and support Installation | 10d | 2019-05-29 | 2019-06-10 | RM03 | 139.25d | 0d | Plumbing Crew [100 h] | 9.43 | MEP | 3 | 1566 | CON |
| A13082 |  | Drainage and Vent Pipe & Fittings | 20d | 2019-06-03 | 2019-06-24 | A13042 SS+5d | 180.25d | 1d | Plumbing Crew [200 h] | 18.86 | MEP | 3 | 1573 | CON |
| A13052 |  | Domestic Water Pipe & Fittings | 20d | 2019-06-03 | 2019-06-25 | A13042 SS+6d | 139.25d | 0d | Plumbing Crew [200 h] | 18.86 | MEP | 3 | 1570 | CON |
|  | 1.4.1.4.1.1.4.1.2.-1 | **2nd Fix** |  | 2019-06-25 | 2019-07-10 |  |  |  |  |  |  |  |  |  |
| A13062 |  | Domestic Water Valves | 12d | 2019-06-25 | 2019-07-07 | A13052 | 139.25d | 0d | Plumbing Crew [120 h] | 11.32 | MEP | 3 | 1571 | CON |
| A13322 |  | Sewege Pumps Installation | 5d | 2019-06-25 | 2019-06-30 | A13082, A13052 | 179.25d | 11d | Plumbing Crew [50 h] | 4.71 | MEP | 3 |  |  |
| A13072 |  | Leak Test | 4d | 2019-07-07 | 2019-07-10 | A13062 | 139.25d | 0d | Plumbing Crew [40 h] | 3.77 | MEP | 3 | 1572 | CON |
|  | 1.4.1.4.1.1.4.1.2.-2 | **PLM_Final Fix** |  | 2019-07-10 | 2019-07-13 |  |  |  |  |  |  |  |  |  |
| A13312 |  | Water Heaters | 2d | 2019-07-10 | 2019-07-13 | A13072, A13082, A13052 | 168.25d | 0d | Plumbing Crew [20 h] | 1.89 | MEP | 3 |  |  |
| A13332 |  | Floor Drain | 2d | 2019-07-10 | 2019-07-13 | A13312 SS | 168.25d | 0d | Plumbing Crew [20 h] | 1.89 | MEP | 3 |  |  |
| A13342 |  | Wash Basin / Water Closet | 2d | 2019-07-10 | 2019-07-13 | A13332 SS | 168.25d | 0d | Plumbing Crew [20 h] | 1.89 | MEP | 3 |  |  |
| A13352 |  | Eye Wash | 2d | 2019-07-10 | 2019-07-13 | A13342 SS, A13322 | 168.25d | 145.75d | Plumbing Crew [20 h] | 1.89 | MEP | 3 |  |  |
|  | 1.4.1.4.1.1.4.1.3 | **ELECTRICAL / CONTROLS** |  | 2019-05-29 | 2019-09-26 |  |  |  |  |  |  |  |  |  |
|  | 1.4.1.4.1.1.4.1.3.1. | **1st Fix** |  | 2019-05-29 | 2019-06-27 |  |  |  |  |  |  |  |  |  |
| A13142 |  | Installation of Conduits and Boxes | 12d | 2019-05-29 | 2019-06-12 | RM03 | 77.25d | 0d | Electrical Crew [120 h] | 11.32 | MEP | 3 | 1592 | CON |
| A13152 |  | Installation of Cable Tray, Ladder and Trunk | 20d | 2019-06-09 | 2019-06-27 | A13142 SS+8d | 148.25d | 0d | Electrical Crew [200 h] | 18.86 | MEP | 3 | 1593 | CON |
|  | 1.4.1.4.1.1.4.1.3.-1 | **2nd Fix** |  | 2019-06-12 | 2019-09-10 |  |  |  |  |  |  |  |  |  |
| A13112 |  | Grounding and Bonding Installation | 20d | 2019-06-12 | 2019-07-01 | A13142 | 77.25d | 0d | Electrical Crew [200 h] | 18.86 | MEP | 3 | 1596 | CON |
| A13532 |  | Installation of Bus Duct System | 20d | 2019-06-27 | 2019-07-16 | A13152 | 148.25d | 56d | Electrical Crew [200 h] | 18.86 | MEP | 3 |  |  |
| A13472 |  | Wire Pulling | 20d | 2019-07-01 | 2019-07-20 | A13112 | 77.25d | 0d | Electrical Crew [200 h] | 18.86 | MEP | 3 |  |  |
| A13092 |  | Power Cable Laying | 25d | 2019-07-20 | 2019-08-15 | A13472, A13112 | 77.25d | 0d | Electrical Crew [250 h] | 23.58 | MEP | 3 | 1600 | CON |
| A13102 |  | Continuity Test - Power Cables | 4d | 2019-08-15 | 2019-08-19 | A13092 | 115.25d | 23d | Electrical Crew [40 h] | 3.77 | MEP | 3 | 1601 | CON |
| A13482 |  | Installation of Central Battery Equipment | 6d | 2019-08-15 | 2019-08-21 | A13092, A13472 | 113.25d | 21d | Electrical Crew [60 h] | 5.66 | MEP | 3 |  |  |
| A13492 |  | Installation of Disconnect Switch | 8d | 2019-08-15 | 2019-08-22 | A13092, A13472 | 111.25d | 19d | Electrical Crew [80 h] | 7.54 | MEP | 3 |  |  |
| A13512 |  | Installation of Switch Boards (MDB, EMDB) | 15d | 2019-08-15 | 2019-08-29 | A13092, A13472 | 77.25d | 0d | Electrical Crew [150 h] | 14.15 | MEP | 3 |  |  |
| A13522 |  | Installation of Panel Boards | 15d | 2019-08-15 | 2019-08-29 | A13092, A13472 | 77.25d | 0d | Electrical Crew [150 h] | 14.15 | MEP | 3 |  |  |
| A13542 |  | Installation of MCC | 15d | 2019-08-15 | 2019-08-29 | A13092, A13472 | 77.25d | 0d | Electrical Crew [150 h] | 14.15 | MEP | 3 |  |  |
| A13552 |  | Installation of Lighting Control System | 12d | 2019-08-15 | 2019-08-27 | A13092, A13472 | 80.25d | 3d | Electrical Crew [120 h] | 11.32 | MEP | 3 |  |  |
| A13502 |  | Installation of Wiring Devices and Outlets | 12d | 2019-08-29 | 2019-09-10 | A13472, A13542, A13522, A13512, A13552 | 77.25d | 0d | Electrical Crew [120 h] | 11.32 | MEP | 3 |  |  |

| ID | WBS | Activity | Duration | Start | Finish | Predecessors | Total float | Free float | Resources | Cost | Discipline | AREA | MSP Activity ID | MEP-Phase |
| --- | --- | --- | --- | --- | --- | --- | --- | --- | --- | --- | --- | --- | --- | --- |
|  | 1.4.1.4.1.1.4.1.3.-2 | **Elec._Final Fix** |  | 2019-08-29 | 2019-09-26 |  |  |  |  |  |  |  |  |  |
| A13562 |  | Panel Board Termination | 8d | 2019-08-29 | 2019-09-05 | A13512, A13522, A13542 | 102.25d | 10d | Electrical Crew [80 h] | 7.54 | MEP | 3 |  |  |
| A13132 |  | Wiring devices Termination | 6d | 2019-09-10 | 2019-09-15 | A13482, A13492, A13532, A13552, A13502, A13102 | 92.25d | 0d | Electrical Crew [60 h] | 5.66 | MEP | 3 | 1617 | CON |
| A13122 |  | Lighting Fixtures Installation and Termination | 10d | 2019-09-16 | 2019-09-26 | A13092, A13472, A13562, A13132 | 92.25d | 77.75d | Electrical Crew [100 h] | 9.43 | MEP | 3 | 1616 | CON |
|  | 1.4.1.4.1.1.4.1.4 | **FIRE FIGHTING SYSTEM** |  | 2019-05-29 | 2019-09-05 |  |  |  |  |  |  |  |  |  |
|  | 1.4.1.4.1.1.4.1.4.1. | **1st Fix** |  | 2019-05-29 | 2019-07-13 |  |  |  |  |  |  |  |  |  |
| A13222 |  | Fire Fighting Hangers & Supports | 15d | 2019-05-29 | 2019-06-15 | RM03 | 106.25d | 0d | Fire Fighting Crew [150 h] | 14.15 | MEP | 3 | 1622 | CON |
| A13192 |  | Pipe Installation | 30d | 2019-06-16 | 2019-07-13 | A13222 | 106.25d | 0d | FF pipe [137 Limt]; FIRE FIGHTING [241 h] | 22.73 | MEP | 3 | 1625 | CON |
|  | 1.4.1.4.1.1.4.1.4.-1 | **2nd Fix** |  | 2019-07-14 | 2019-08-13 |  |  |  |  |  |  |  |  |  |
| A13202 |  | Valve and Accessories Installation | 20d | 2019-07-14 | 2019-07-31 | A13192, A13222 | 106.25d | 0d | Fire Fighting Crew [200 h] | 18.86 | MEP | 3 | 1627 | CON |
| A13212 |  | Leak Test | 10d | 2019-08-01 | 2019-08-13 | A13202 | 106.25d | 0d | Fire Fighting Crew [100 h] | 9.43 | MEP | 3 | 1631 | CON |
|  | 1.4.1.4.1.1.4.1.4.-2 | **FF_Final Fix** |  | 2019-08-14 | 2019-09-05 |  |  |  |  |  |  |  |  |  |
| A13232 |  | Installation of Sprinklers | 15d | 2019-08-14 | 2019-08-27 | A13192, A13202, A13212 | 122.25d | 0d | Fire Fighting Crew [150 h] | 14.15 | MEP | 3 | 1633 | CON |
| A13242 |  | Instalaltion of Fire Extinguisher | 10d | 2019-08-28 | 2019-09-05 | A13192, A13232, A13572 FF | 177.25d | 177.75d | Fire Fighting Crew [100 h] | 9.43 | MEP | 3 |  | CON |
| A13572 |  | Installation of Fire hose Cabinet | 5d | 2019-08-28 | 2019-09-01 | A13192, A13232 | 182.25d | 5d | Fire Fighting Crew [50 h] | 4.71 | MEP | 3 |  |  |
|  | 3 | **B07 - UNDER PLATFORM ZONE 07** |  | 2019-05-29 | 2019-09-26 |  |  |  |  |  |  |  |  |  |
|  | 1.4.1.4.1.1.4.1.1 | **HVAC SYSTEM** |  | 2019-05-29 | 2019-07-28 |  |  |  |  |  |  |  |  |  |
|  | 1.4.1.4.1.1.4.1.1.1. | **1st Fix** |  | 2019-05-29 | 2019-06-18 |  |  |  |  |  |  |  |  |  |
| A15342 |  | Hanger and support Installation - Duct | 6d | 2019-05-29 | 2019-06-03 | RM03 | 143.25d | 0d | Mechanical Crew [60 h] | 5.66 | MEP | 3 | 1546 | CON |
| A15412 |  | Hanger and support Installation - CHW | 6d | 2019-05-29 | 2019-06-03 | A15342 SS | 143.25d | 0d | Mechanical Crew [60 h] | 5.66 | MEP | 3 |  |  |
| A15322 |  | Duct Installation | 12d | 2019-05-30 | 2019-06-15 | A15342 SS+2d | 160.25d | 0d | Duct Installation [174 Sqmt]; HVAC [520 h] | 49.04 | MEP | 3 | 1549 | CON |
| A15332 |  | Duct Insulation | 8d | 2019-06-03 | 2019-06-13 | A15322 SS+3d | 184.25d | 33d | Duct Insulation [180 Sqmt]; HVAC [128 h] | 12.07 | MEP | 3 | 1552 | CON |
| A15432 |  | Chilled Water Piping Installation | 12d | 2019-06-03 | 2019-06-18 | A15412 | 143.25d | 0d | Mechanical Crew [120 h] | 11.32 | MEP | 3 |  |  |
|  | 1.4.1.4.1.1.4.1.1.-1 | **2nd Fix** |  | 2019-06-15 | 2019-07-07 |  |  |  |  |  |  |  |  |  |
| A15422 |  | Installation of Duct Accessories (VD, FD, MSD etc....) | 12d | 2019-06-15 | 2019-06-25 | A15322 | 171.25d | 20d | Mechanical Crew [120 h] | 11.32 | MEP | 3 |  |  |
| A15522 |  | CRAC Units Installation | 15d | 2019-06-15 | 2019-06-29 | A15322 | 160.25d | 9d | Mechanical Crew [150 h] | 14.15 | MEP | 3 |  |  |
| A15532 |  | FCU Installation | 15d | 2019-06-15 | 2019-06-29 | A15322 | 160.25d | 9d | Mechanical Crew [150 h] | 14.15 | MEP | 3 |  |  |
| A15542 |  | VRF DX Units Installation | 12d | 2019-06-15 | 2019-06-25 | A15322 | 163.25d | 12d | Mechanical Crew [120 h] | 11.32 | MEP | 3 |  |  |
| A15552 |  | Installation of Attenuators | 10d | 2019-06-15 | 2019-06-24 | A15322 | 165.25d | 14d | Mechanical Crew [100 h] | 9.43 | MEP | 3 |  |  |
| A15562 |  | Installation of HVAC Fans | 10d | 2019-06-15 | 2019-06-24 | A15322 | 165.25d | 14d | Mechanical Crew [100 h] | 9.43 | MEP | 3 |  |  |
| A15582 |  | Pressurization Unit | 8d | 2019-06-15 | 2019-06-22 | A15322 | 167.25d | 16d | Mechanical Crew [80 h] | 7.54 | MEP | 3 |  |  |
| A15592 |  | Dosing pot | 5d | 2019-06-15 | 2019-06-19 | A15322 | 170.25d | 19d | Mechanical Crew [50 h] | 4.71 | MEP | 3 |  |  |
| A15612 |  | Air Handling Units Installation | 12d | 2019-06-15 | 2019-06-25 | A15322 | 163.25d | 12d | Mechanical Crew [120 h] | 11.32 | MEP | 3 |  |  |
| A15452 |  | Valves and Accessories | 10d | 2019-06-18 | 2019-06-27 | A15432 | 143.25d | 0d | Mechanical Crew [100 h] | 9.43 | MEP | 3 |  |  |
| A15572 |  | Air-Cooled Chillers | 15d | 2019-06-18 | 2019-07-02 | A15432 | 156.25d | 5d | Mechanical Crew [150 h] | 14.15 | MEP | 3 |  |  |
| A15622 |  | Chilled Water Pump Installation | 12d | 2019-06-18 | 2019-06-29 | A15432 | 159.25d | 8d | Mechanical Crew [120 h] | 11.32 | MEP | 3 |  |  |
| A15462 |  | Chilled Water Pipe Insulation and Cladding | 10d | 2019-06-27 | 2019-07-07 | A15432, A15452 | 143.25d | 0d | Mechanical Crew [100 h] | 9.43 | MEP | 3 |  |  |

| ID | WBS | Activity | Duration | Start | Finish | Predecessors | Total float | Free float | Resources | Cost | Discipline | AREA | MSP Activity ID | MEP-Phase |
| --- | --- | --- | --- | --- | --- | --- | --- | --- | --- | --- | --- | --- | --- | --- |
|  | 1.4.1.4.1.1.4.1.1.-2 | **HVAC_Final Fix** |  | 2019-07-07 | 2019-07-28 |  |  |  |  |  |  |  |  |  |
| A15602 |  | Equuipment Connection | 8d | 2019-07-07 | 2019-07-14 | A15622, A15612, A15572, A15562, A15552, A15522, A15532, A15542, A15592, A15582, A15462 | 151.25d | 0d | Mechanical Crew [80 h] | 7.54 | MEP | 3 |  |  |
| A15442 |  | Air Outlets (Grills, Diffusers, Registers etc...) | 15d | 2019-07-14 | 2019-07-28 | A15422, A15322, A15332, A15602 | 151.25d | 141.75d | Mechanical Crew [150 h] | 14.15 | MEP | 3 |  |  |
|  | 1.4.1.4.1.1.4.1.2 | **PLUMBING SYSTEM** |  | 2019-05-29 | 2019-07-13 |  |  |  |  |  |  |  |  |  |
|  | 1.4.1.4.1.1.4.1.2.1. | **1st Fix** |  | 2019-05-29 | 2019-06-25 |  |  |  |  |  |  |  |  |  |
| A15202 |  | Hanger and support Installation | 10d | 2019-05-29 | 2019-06-10 | RM03 | 139.25d | 0d | Plumbing Crew [100 h] | 9.43 | MEP | 3 | 1566 | CON |
| A15242 |  | Drainage and Vent Pipe & Fittings | 20d | 2019-06-03 | 2019-06-24 | A15202 SS+5d | 180.25d | 1d | Plumbing Crew [200 h] | 18.86 | MEP | 3 | 1573 | CON |
| A15212 |  | Domestic Water Pipe & Fittings | 20d | 2019-06-03 | 2019-06-25 | A15202 SS+6d | 139.25d | 0d | Plumbing Crew [200 h] | 18.86 | MEP | 3 | 1570 | CON |
|  | 1.4.1.4.1.1.4.1.2.-1 | **2nd Fix** |  | 2019-06-25 | 2019-07-10 |  |  |  |  |  |  |  |  |  |
| A15222 |  | Domestic Water Valves | 12d | 2019-06-25 | 2019-07-07 | A15212 | 139.25d | 0d | Plumbing Crew [120 h] | 11.32 | MEP | 3 | 1571 | CON |
| A15482 |  | Sewege Pumps Installation | 5d | 2019-06-25 | 2019-06-30 | A15242, A15212 | 179.25d | 11d | Plumbing Crew [50 h] | 4.71 | MEP | 3 |  |  |
| A15232 |  | Leak Test | 4d | 2019-07-07 | 2019-07-10 | A15222 | 139.25d | 0d | Plumbing Crew [40 h] | 3.77 | MEP | 3 | 1572 | CON |
|  | 1.4.1.4.1.1.4.1.2.-2 | **PLM_Final Fix** |  | 2019-07-10 | 2019-07-13 |  |  |  |  |  |  |  |  |  |
| A15472 |  | Water Heaters | 2d | 2019-07-10 | 2019-07-13 | A15232, A15242, A15212 | 168.25d | 0d | Plumbing Crew [20 h] | 1.89 | MEP | 3 |  |  |
| A15492 |  | Floor Drain | 2d | 2019-07-10 | 2019-07-13 | A15472 SS | 168.25d | 0d | Plumbing Crew [20 h] | 1.89 | MEP | 3 |  |  |
| A15502 |  | Wash Basin / Water Closet | 2d | 2019-07-10 | 2019-07-13 | A15492 SS | 168.25d | 0d | Plumbing Crew [20 h] | 1.89 | MEP | 3 |  |  |
| A15512 |  | Eye Wash | 2d | 2019-07-10 | 2019-07-13 | A15502 SS, A15482 | 168.25d | 145.75d | Plumbing Crew [20 h] | 1.89 | MEP | 3 |  |  |
|  | 1.4.1.4.1.1.4.1.3 | **ELECTRICAL / CONTROLS** |  | 2019-05-29 | 2019-09-26 |  |  |  |  |  |  |  |  |  |
|  | 1.4.1.4.1.1.4.1.3.1. | **1st Fix** |  | 2019-05-29 | 2019-06-27 |  |  |  |  |  |  |  |  |  |
| A15302 |  | Installation of Conduits and Boxes | 12d | 2019-05-29 | 2019-06-12 | RM03 | 77.25d | 0d | Electrical Crew [120 h] | 11.32 | MEP | 3 | 1592 | CON |
| A15312 |  | Installation of Cable Tray, Ladder and Trunk | 20d | 2019-06-09 | 2019-06-27 | A15302 SS+8d | 148.25d | 0d | Electrical Crew [200 h] | 18.86 | MEP | 3 | 1593 | CON |
|  | 1.4.1.4.1.1.4.1.3.-1 | **2nd Fix** |  | 2019-06-12 | 2019-09-10 |  |  |  |  |  |  |  |  |  |
| A15272 |  | Grounding and Bonding Installation | 20d | 2019-06-12 | 2019-07-01 | A15302 | 77.25d | 0d | Electrical Crew [200 h] | 18.86 | MEP | 3 | 1596 | CON |
| A15692 |  | Installation of Bus Duct System | 20d | 2019-06-27 | 2019-07-16 | A15312 | 148.25d | 56d | Electrical Crew [200 h] | 18.86 | MEP | 3 |  |  |
| A15632 |  | Wire Pulling | 20d | 2019-07-01 | 2019-07-20 | A15272 | 77.25d | 0d | Electrical Crew [200 h] | 18.86 | MEP | 3 |  |  |
| A15252 |  | Power Cable Laying | 25d | 2019-07-20 | 2019-08-15 | A15632, A15272 | 77.25d | 0d | Electrical Crew [250 h] | 23.58 | MEP | 3 | 1600 | CON |
| A15262 |  | Continuity Test - Power Cables | 4d | 2019-08-15 | 2019-08-19 | A15252 | 115.25d | 23d | Electrical Crew [40 h] | 3.77 | MEP | 3 | 1601 | CON |
| A15642 |  | Installation of Central Battery Equipment | 6d | 2019-08-15 | 2019-08-21 | A15252, A15632 | 113.25d | 21d | Electrical Crew [60 h] | 5.66 | MEP | 3 |  |  |
| A15652 |  | Installation of Disconnect Switch | 8d | 2019-08-15 | 2019-08-22 | A15252, A15632 | 111.25d | 19d | Electrical Crew [80 h] | 7.54 | MEP | 3 |  |  |
| A15672 |  | Installation of Switch Boards (MDB, EMDB) | 15d | 2019-08-15 | 2019-08-29 | A15252, A15632 | 77.25d | 0d | Electrical Crew [150 h] | 14.15 | MEP | 3 |  |  |
| A15682 |  | Installation of Panel Boards | 15d | 2019-08-15 | 2019-08-29 | A15252, A15632 | 77.25d | 0d | Electrical Crew [150 h] | 14.15 | MEP | 3 |  |  |
| A15702 |  | Installation of MCC | 15d | 2019-08-15 | 2019-08-29 | A15252, A15632 | 77.25d | 0d | Electrical Crew [150 h] | 14.15 | MEP | 3 |  |  |
| A15712 |  | Installation of Lighting Control System | 12d | 2019-08-15 | 2019-08-27 | A15252, A15632 | 80.25d | 3d | Electrical Crew [120 h] | 11.32 | MEP | 3 |  |  |
| A15662 |  | Installation of Wiring Devices and Outlets | 12d | 2019-08-29 | 2019-09-10 | A15632, A15702, A15682, A15672, A15712 | 77.25d | 0d | Electrical Crew [120 h] | 11.32 | MEP | 3 |  |  |

| ID | WBS | Activity | Type | Duration | Start | Finish | Predecessors | Total float | Free float | Calendar | Resources | Cost | Discipline | AREA | MSP Activity ID | MEP-Phase |
| --- | --- | --- | --- | --- | --- | --- | --- | --- | --- | --- | --- | --- | --- | --- | --- | --- |
|  | 1.4.1.4.1.1.4.1.3.-2 | **Elec._Final Fix** |  |  | 2019-08-29 | 2019-09-26 |  |  |  |  |  |  |  |  |  |  |
| A15722 |  | Panel Board Termination |  | 8d | 2019-08-29 | 2019-09-05 | A15672, A15682, A15702 | 102.25d | 10d |  | Electrical Crew [80 h] | 7.54 | MEP | 3 |  |  |
| A15292 |  | Wiring devices Termination |  | 6d | 2019-09-10 | 2019-09-15 | A15642, A15652, A15692, A15712, A15662, A15262 | 92.25d | 0d |  | Electrical Crew [60 h] | 5.66 | MEP | 3 | 1617 | CON |
| A15282 |  | Lighting Fixtures Installation and Termination |  | 10d | 2019-09-16 | 2019-09-26 | A15252, A15632, A15722, A15292 | 92.25d | 77.75d |  | Electrical Crew [100 h] | 9.43 | MEP | 3 | 1616 | CON |
|  | 1.4.1.4.1.1.4.1.4 | **FIRE FIGHTING SYSTEM** |  |  | 2019-05-29 | 2019-09-05 |  |  |  |  |  |  |  |  |  |  |
|  | 1.4.1.4.1.1.4.1.4.1. | **1st Fix** |  |  | 2019-05-29 | 2019-07-13 |  |  |  |  |  |  |  |  |  |  |
| A15382 |  | Fire Fighting Hangers & Supports |  | 15d | 2019-05-29 | 2019-06-15 | RM03 | 106.25d | 0d |  | Fire Fighting Crew [150 h] | 14.15 | MEP | 3 | 1622 | CON |
| A15352 |  | Pipe Installation |  | 30d | 2019-06-16 | 2019-07-13 | A15382 | 106.25d | 0d |  | FIRE FIGHTING [241 h]; FF pipe [137 Limt] | 22.73 | MEP | 3 | 1625 | CON |
|  | 1.4.1.4.1.1.4.1.4.-1 | **2nd Fix** |  |  | 2019-07-14 | 2019-08-13 |  |  |  |  |  |  |  |  |  |  |
| A15362 |  | Valve and Accessories Installation |  | 20d | 2019-07-14 | 2019-07-31 | A15352, A15382 | 106.25d | 0d |  | Fire Fighting Crew [200 h] | 18.86 | MEP | 3 | 1627 | CON |
| A15372 |  | Leak Test |  | 10d | 2019-08-01 | 2019-08-13 | A15362 | 106.25d | 0d |  | Fire Fighting Crew [100 h] | 9.43 | MEP | 3 | 1631 | CON |
|  | 1.4.1.4.1.1.4.1.4.-2 | **FF_Final Fix** |  |  | 2019-08-14 | 2019-09-05 |  |  |  |  |  |  |  |  |  |  |
| A15392 |  | Installation of Sprinklers |  | 15d | 2019-08-14 | 2019-08-27 | A15352, A15362, A15372 | 122.25d | 0d |  | Fire Fighting Crew [150 h] | 14.15 | MEP | 3 | 1633 | CON |
| A15402 |  | Instalaltion of Fire Extinguisher |  | 10d | 2019-08-28 | 2019-09-05 | A15352, A15392, A15732 FF | 177.25d | 177.75d |  | Fire Fighting Crew [100 h] | 9.43 | MEP | 3 |  | CON |
| A15732 |  | Installation of Fire hose Cabinet |  | 5d | 2019-08-28 | 2019-09-01 | A15352, A15392 | 182.25d | 5d |  | Fire Fighting Crew [50 h] | 4.71 | MEP | 3 |  |  |
|  | 2 | **NORTH UNDER PLATFORM ZONE (1 TO 4)** |  |  | 2019-04-29 | 2019-08-27 |  |  |  |  |  |  |  |  |  |  |
| LOE-SUM3-050 |  | North . B07 - MEP Works; 1st & 2nd Fix | level of effort | 114d | 2019-04-29 | 2019-08-13 | RM04 | 154.75d | 0d | Saudi |  |  | MEP |  |  |  |
| LOE-SUM3-060 |  | North . B07 - MEP Works; Final Fix | level of effort | 92d | 2019-06-03 | 2019-08-27 | A24242 SS | 123.75d | 0d | Saudi |  |  | MEP |  |  |  |
|  | 2 | **B07 - UNDER PLATFORM ZONE 01** |  |  | 2019-05-01 | 2019-08-27 |  |  |  |  |  |  |  |  |  |  |
|  | 1.4.1.4.1.1.4.1.1 | **HVAC SYSTEM** |  |  | 2019-05-01 | 2019-06-30 |  |  |  |  |  |  |  |  |  |  |
|  | 1.4.1.4.1.1.4.1.1.1. | **1st Fix** |  |  | 2019-05-01 | 2019-05-18 |  |  |  |  |  |  |  |  |  |  |
| A17502 |  | Hanger and support Installation - Duct |  | 6d | 2019-05-01 | 2019-05-06 | RM05 | 181.25d | 0d |  | Mechanical Crew [60 h] | 5.66 | MEP | 1 | 1546 | CON |
| A17572 |  | Hanger and support Installation - CHW |  | 6d | 2019-05-01 | 2019-05-06 | A17502 SS | 181.25d | 0d |  | Mechanical Crew [60 h] | 5.66 | MEP | 1 |  |  |
| A17482 |  | Duct Installation |  | 12d | 2019-05-02 | 2019-05-14 | A17502 SS+2d | 190.25d | 0d |  | Duct Installation [130 Sqmt]; HVAC [390 h] | 36.78 | MEP | 1 | 1549 | CON |
| A17492 |  | Duct Insulation |  | 8d | 2019-05-06 | 2019-05-13 | A17482 SS+3d | 214.25d | 33d |  | Duct Insulation [145 Sqmt]; HVAC [90 h] | 8.49 | MEP | 1 | 1552 | CON |
| A17592 |  | Chilled Water Piping Installation |  | 12d | 2019-05-06 | 2019-05-18 | A17572 | 181.25d | 0d |  | Mechanical Crew [120 h] | 11.32 | MEP | 1 |  |  |

| ID | WBS | Activity | Duration | Start | Finish | Predecessors | Total float | Free float | Resources | Cost | Discipline | AREA | MSP Activity ID | MEP-Phase |
| --- | --- | --- | --- | --- | --- | --- | --- | --- | --- | --- | --- | --- | --- | --- |
|  | 1.4.1.4.1.1.4.1.1.-1 | **2nd Fix** |  | 2019-05-14 | 2019-06-09 |  |  |  |  |  |  |  |  |  |
| A17582 |  | Installation of Duct Accessories (VD, FD, MSD etc....) | 12d | 2019-05-14 | 2019-05-25 | A17482 | 201.25d | 20d | Mechanical Crew [120 h] | 11.32 | MEP | 1 |  |  |
| A17682 |  | CRAC Units Installation | 15d | 2019-05-14 | 2019-05-28 | A17482 | 190.25d | 9d | Mechanical Crew [150 h] | 14.15 | MEP | 1 |  |  |
| A17692 |  | FCU Installation | 15d | 2019-05-14 | 2019-05-28 | A17482 | 190.25d | 9d | Mechanical Crew [150 h] | 14.15 | MEP | 1 |  |  |
| A17702 |  | VRF DX Units Installation | 12d | 2019-05-14 | 2019-05-25 | A17482 | 193.25d | 12d | Mechanical Crew [120 h] | 11.32 | MEP | 1 |  |  |
| A17712 |  | Installation of Attenuators | 10d | 2019-05-14 | 2019-05-23 | A17482 | 195.25d | 14d | Mechanical Crew [100 h] | 9.43 | MEP | 1 |  |  |
| A17722 |  | Installation of HVAC Fans | 10d | 2019-05-14 | 2019-05-23 | A17482 | 195.25d | 14d | Mechanical Crew [100 h] | 9.43 | MEP | 1 |  |  |
| A17742 |  | Pressurization Unit | 8d | 2019-05-14 | 2019-05-21 | A17482 | 197.25d | 16d | Mechanical Crew [80 h] | 7.54 | MEP | 1 |  |  |
| A17752 |  | Dosing pot | 5d | 2019-05-14 | 2019-05-19 | A17482 | 200.25d | 19d | Mechanical Crew [50 h] | 4.71 | MEP | 1 |  |  |
| A17772 |  | Air Handling Units Installation | 12d | 2019-05-14 | 2019-05-25 | A17482 | 193.25d | 12d | Mechanical Crew [120 h] | 11.32 | MEP | 1 |  |  |
| A17612 |  | Valves and Accessories | 10d | 2019-05-18 | 2019-05-27 | A17592 | 181.25d | 0d | Mechanical Crew [100 h] | 9.43 | MEP | 1 |  |  |
| A17732 |  | Air-Cooled Chillers | 15d | 2019-05-18 | 2019-06-01 | A17592 | 186.25d | 5d | Mechanical Crew [150 h] | 14.15 | MEP | 1 |  |  |
| A17782 |  | Chilled Water Pump Installation | 12d | 2019-05-18 | 2019-05-28 | A17592 | 189.25d | 8d | Mechanical Crew [120 h] | 11.32 | MEP | 1 |  |  |
| A17622 |  | Chilled Water Pipe Insulation and Cladding | 10d | 2019-05-27 | 2019-06-09 | A17592, A17612 | 181.25d | 0d | Mechanical Crew [100 h] | 9.43 | MEP | 1 |  |  |
|  | 1.4.1.4.1.1.4.1.1.-2 | **HVAC_Final Fix** |  | 2019-06-09 | 2019-06-30 |  |  |  |  |  |  |  |  |  |
| A17762 |  | Equuipment Connection | 8d | 2019-06-09 | 2019-06-16 | A17782, A17772, A17732, A17722, A17712, A17682, A17692, A17702, A17752, A17742, A17622 | 181.25d | 0d | Mechanical Crew [80 h] | 7.54 | MEP | 1 |  |  |
| A17602 |  | Air Outlets (Grills, Diffusers, Registers etc...) | 15d | 2019-06-16 | 2019-06-30 | A17582, A17482, A17492, A17762 | 181.25d | 171.75d | Mechanical Crew [150 h] | 14.15 | MEP | 1 |  |  |
|  | 1.4.1.4.1.1.4.1.2 | **PLUMBING SYSTEM** |  | 2019-05-01 | 2019-06-15 |  |  |  |  |  |  |  |  |  |
|  | 1.4.1.4.1.1.4.1.2.1. | **1st Fix** |  | 2019-05-01 | 2019-05-25 |  |  |  |  |  |  |  |  |  |
| A17362 |  | Hanger and support Installation | 10d | 2019-05-01 | 2019-05-09 | RM05 | 198.25d | 0d | Plumbing Crew [100 h] | 9.43 | MEP | 1 | 1566 | CON |
| A17402 |  | Drainage and Vent Pipe & Fittings | 20d | 2019-05-06 | 2019-05-23 | A17362 SS+5d | 210.25d | 1d | Plumbing Crew [200 h] | 18.86 | MEP | 1 | 1573 | CON |
| A17372 |  | Domestic Water Pipe & Fittings | 20d | 2019-05-06 | 2019-05-25 | A17362 SS+6d | 198.25d | 0d | Plumbing Crew [200 h] | 18.86 | MEP | 1 | 1570 | CON |
|  | 1.4.1.4.1.1.4.1.2.-1 | **2nd Fix** |  | 2019-05-25 | 2019-06-12 |  |  |  |  |  |  |  |  |  |
| A17382 |  | Domestic Water Valves | 12d | 2019-05-25 | 2019-06-09 | A17372 | 198.25d | 0d | Plumbing Crew [120 h] | 11.32 | MEP | 1 | 1571 | CON |
| A17642 |  | Sewege Pumps Installation | 5d | 2019-05-25 | 2019-05-29 | A17402, A17372 | 209.25d | 11d | Plumbing Crew [50 h] | 4.71 | MEP | 1 |  |  |
| A17392 |  | Leak Test | 4d | 2019-06-09 | 2019-06-12 | A17382 | 198.25d | 0d | Plumbing Crew [40 h] | 3.77 | MEP | 1 | 1572 | CON |

| ID | WBS | Activity | Duration | Start | Finish | Predecessors | Total float | Free float | Resources | Cost | Discipline | AREA | MSP Activity ID | MEP-Phase |
| --- | --- | --- | --- | --- | --- | --- | --- | --- | --- | --- | --- | --- | --- | --- |
|  | 1.4.1.4.1.1.4.1.2.-2 | **PLM_Final Fix** |  | 2019-06-12 | 2019-06-15 |  |  |  |  |  |  |  |  |  |
| A17632 |  | Water Heaters | 2d | 2019-06-12 | 2019-06-15 | A17392, A17402, A17372 | 198.25d | 0d | Plumbing Crew [20 h] | 1.89 | MEP | 1 |  |  |
| A17652 |  | Floor Drain | 2d | 2019-06-12 | 2019-06-15 | A17632 SS | 198.25d | 0d | Plumbing Crew [20 h] | 1.89 | MEP | 1 |  |  |
| A17662 |  | Wash Basin / Water Closet | 2d | 2019-06-12 | 2019-06-15 | A17652 SS | 198.25d | 0d | Plumbing Crew [20 h] | 1.89 | MEP | 1 |  |  |
| A17672 |  | Eye Wash | 2d | 2019-06-12 | 2019-06-15 | A17662 SS, A17642 | 198.25d | 175.75d | Plumbing Crew [20 h] | 1.89 | MEP | 1 |  |  |
|  | 1.4.1.4.1.1.4.1.3 | **ELECTRICAL / CONTROLS** |  | 2019-05-01 | 2019-08-27 |  |  |  |  |  |  |  |  |  |
|  | 1.4.1.4.1.1.4.1.3.1. | **1st Fix** |  | 2019-05-01 | 2019-05-27 |  |  |  |  |  |  |  |  |  |
| A17462 |  | Installation of Conduits and Boxes | 12d | 2019-05-01 | 2019-05-12 | RM05 | 122.25d | 0d | Electrical Crew [120 h] | 11.32 | MEP | 1 | 1592 | CON |
| A17472 |  | Installation of Cable Tray, Ladder and Trunk | 20d | 2019-05-08 | 2019-05-27 | A17462 SS+8d | 178.25d | 0d | Electrical Crew [200 h] | 18.86 | MEP | 1 | 1593 | CON |
|  | 1.4.1.4.1.1.4.1.3.-1 | **2nd Fix** |  | 2019-05-12 | 2019-08-13 |  |  |  |  |  |  |  |  |  |
| A17432 |  | Grounding and Bonding Installation | 20d | 2019-05-12 | 2019-05-30 | A17462 | 122.25d | 0d | Electrical Crew [200 h] | 18.86 | MEP | 1 | 1596 | CON |
| A17852 |  | Installation of Bus Duct System | 20d | 2019-05-27 | 2019-06-18 | A17472 | 178.25d | 56d | Electrical Crew [200 h] | 18.86 | MEP | 1 |  |  |
| A17792 |  | Wire Pulling | 20d | 2019-05-30 | 2019-06-22 | A17432 | 122.25d | 0d | Electrical Crew [200 h] | 18.86 | MEP | 1 |  |  |
| A17412 |  | Power Cable Laying | 25d | 2019-06-22 | 2019-07-15 | A17792, A17432 | 122.25d | 0d | Electrical Crew [250 h] | 23.58 | MEP | 1 | 1600 | CON |
| A17422 |  | Continuity Test - Power Cables | 4d | 2019-07-15 | 2019-07-18 | A17412 | 145.25d | 23d | Electrical Crew [40 h] | 3.77 | MEP | 1 | 1601 | CON |
| A17802 |  | Installation of Central Battery Equipment | 6d | 2019-07-15 | 2019-07-21 | A17412, A17792 | 143.25d | 21d | Electrical Crew [60 h] | 5.66 | MEP | 1 |  |  |
| A17812 |  | Installation of Disconnect Switch | 8d | 2019-07-15 | 2019-07-22 | A17412, A17792 | 141.25d | 19d | Electrical Crew [80 h] | 7.54 | MEP | 1 |  |  |
| A17832 |  | Installation of Switch Boards (MDB, EMDB) | 15d | 2019-07-15 | 2019-07-29 | A17412, A17792 | 122.25d | 0d | Electrical Crew [150 h] | 14.15 | MEP | 1 |  |  |
| A17842 |  | Installation of Panel Boards | 15d | 2019-07-15 | 2019-07-29 | A17412, A17792 | 122.25d | 0d | Electrical Crew [150 h] | 14.15 | MEP | 1 |  |  |
| A17862 |  | Installation of MCC | 15d | 2019-07-15 | 2019-07-29 | A17412, A17792 | 122.25d | 0d | Electrical Crew [150 h] | 14.15 | MEP | 1 |  |  |
| A17872 |  | Installation of Lighting Control System | 12d | 2019-07-15 | 2019-07-27 | A17412, A17792 | 125.25d | 3d | Electrical Crew [120 h] | 11.32 | MEP | 1 |  |  |
| A17822 |  | Installation of Wiring Devices and Outlets | 12d | 2019-07-29 | 2019-08-13 | A17792, A17862, A17842, A17832, A17872 | 122.25d | 0d | Electrical Crew [120 h] | 11.32 | MEP | 1 |  |  |
|  | 1.4.1.4.1.1.4.1.3.-2 | **Elec._Final Fix** |  | 2019-07-29 | 2019-08-27 |  |  |  |  |  |  |  |  |  |
| A17882 |  | Panel Board Termination | 8d | 2019-07-29 | 2019-08-05 | A17832, A17842, A17862 | 132.25d | 10d | Electrical Crew [80 h] | 7.54 | MEP | 1 |  |  |
| A17452 |  | Wiring devices Termination | 6d | 2019-08-13 | 2019-08-18 | A17802, A17812, A17852, A17872, A17822, A17422 | 122.25d | 0d | Electrical Crew [60 h] | 5.66 | MEP | 1 | 1617 | CON |
| A17442 |  | Lighting Fixtures Installation and Termination | 10d | 2019-08-19 | 2019-08-27 | A17412, A17792, A17882, A17452, LOE-SUM3-060 FF | 122.25d | 107.75d | Electrical Crew [100 h] | 9.43 | MEP | 1 | 1616 | CON |

| ID | WBS | Activity | Duration | Start | Finish | Predecessors | Total float | Free float | Resources | Cost | MSP Activity ID | Discipline | MEP-Phase | AREA |
| --- | --- | --- | --- | --- | --- | --- | --- | --- | --- | --- | --- | --- | --- | --- |
|  | 1.4.1.4.1.1.4.1.4 | **FIRE FIGHTING SYSTEM** |  | 2019-05-01 | 2019-08-05 |  |  |  |  |  |  |  |  |  |
|  | 1.4.1.4.1.1.4.1.4.1. | **1st Fix** |  | 2019-05-01 | 2019-06-15 |  |  |  |  |  |  |  |  |  |
| A17542 |  | Fire Fighting Hangers & Supports | 15d | 2019-05-01 | 2019-05-14 | RM05 | 152.25d | 0d | Fire Fighting Crew [150 h] | 14.15 | 1622 | MEP | CON | 1 |
| A17512 |  | Pipe Installation | 30d | 2019-05-15 | 2019-06-15 | A17542 | 152.25d | 0d | FF pipe [103 Limt]; FIRE FIGHTING [180 h] | 16.97 | 1625 | MEP | CON | 1 |
|  | 1.4.1.4.1.1.4.1.4.-1 | **2nd Fix** |  | 2019-06-16 | 2019-07-13 |  |  |  |  |  |  |  |  |  |
| A17522 |  | Valve and Accessories Installation | 20d | 2019-06-16 | 2019-07-03 | A17512, A17542 | 152.25d | 0d | Fire Fighting Crew [200 h] | 18.86 | 1627 | MEP | CON | 1 |
| A17532 |  | Leak Test | 10d | 2019-07-04 | 2019-07-13 | A17522 | 152.25d | 0d | Fire Fighting Crew [100 h] | 9.43 | 1631 | MEP | CON | 1 |
|  | 1.4.1.4.1.1.4.1.4.-2 | **FF_Final Fix** |  | 2019-07-14 | 2019-08-05 |  |  |  |  |  |  |  |  |  |
| A17552 |  | Installation of Sprinklers | 15d | 2019-07-14 | 2019-07-27 | A17512, A17522, A17532 | 152.25d | 0d | Fire Fighting Crew [150 h] | 14.15 | 1633 | MEP | CON | 1 |
| A17562 |  | Instalaltion of Fire Extinguisher | 10d | 2019-07-28 | 2019-08-05 | A17512, A17552, A17892 FF | 207.25d | 207.75d | Fire Fighting Crew [100 h] | 9.43 |  | MEP | CON | 1 |
| A17892 |  | Installation of Fire hose Cabinet | 5d | 2019-07-28 | 2019-07-31 | A17512, A17552 | 212.25d | 5d | Fire Fighting Crew [50 h] | 4.71 |  | MEP |  | 1 |
|  | 1 | **B07 - UNDER PLATFORM ZONE 02** |  | 2019-05-01 | 2019-08-27 |  |  |  |  |  |  |  |  |  |
|  | 1.4.1.4.1.1.4.1.1 | **HVAC SYSTEM** |  | 2019-05-01 | 2019-06-30 |  |  |  |  |  |  |  |  |  |
|  | 1.4.1.4.1.1.4.1.1.1. | **1st Fix** |  | 2019-05-01 | 2019-05-18 |  |  |  |  |  |  |  |  |  |
| A19662 |  | Hanger and support Installation - Duct | 6d | 2019-05-01 | 2019-05-06 | RM05 | 181.25d | 0d | Mechanical Crew [60 h] | 5.66 | 1546 | MEP | CON | 1 |
| A19732 |  | Hanger and support Installation - CHW | 6d | 2019-05-01 | 2019-05-06 | A19662 SS | 181.25d | 0d | Mechanical Crew [60 h] | 5.66 |  | MEP |  | 1 |
| A19642 |  | Duct Installation | 12d | 2019-05-02 | 2019-05-14 | A19662 SS+2d | 190.25d | 0d | Duct Installation [130 Sqmt]; HVAC [390 h] | 36.78 | 1549 | MEP | CON | 1 |
| A19652 |  | Duct Insulation | 8d | 2019-05-06 | 2019-05-13 | A19642 SS+3d | 214.25d | 33d | Duct Insulation [145 Sqmt]; HVAC [90 h] | 8.49 | 1552 | MEP | CON | 1 |
| A19752 |  | Chilled Water Piping Installation | 12d | 2019-05-06 | 2019-05-18 | A19732 | 181.25d | 0d | Mechanical Crew [120 h] | 11.32 |  | MEP |  | 1 |
|  | 1.4.1.4.1.1.4.1.1.-1 | **2nd Fix** |  | 2019-05-14 | 2019-06-09 |  |  |  |  |  |  |  |  |  |
| A19742 |  | Installation of Duct Accessories (VD, FD, MSD etc....) | 12d | 2019-05-14 | 2019-05-25 | A19642 | 201.25d | 20d | Mechanical Crew [120 h] | 11.32 |  | MEP |  | 1 |
| A19842 |  | CRAC Units Installation | 15d | 2019-05-14 | 2019-05-28 | A19642 | 190.25d | 9d | Mechanical Crew [150 h] | 14.15 |  | MEP |  | 1 |
| A19852 |  | FCU Installation | 15d | 2019-05-14 | 2019-05-28 | A19642 | 190.25d | 9d | Mechanical Crew [150 h] | 14.15 |  | MEP |  | 1 |
| A19862 |  | VRF DX Units Installation | 12d | 2019-05-14 | 2019-05-25 | A19642 | 193.25d | 12d | Mechanical Crew [120 h] | 11.32 |  | MEP |  | 1 |
| A19872 |  | Installation of Attenuators | 10d | 2019-05-14 | 2019-05-23 | A19642 | 195.25d | 14d | Mechanical Crew [100 h] | 9.43 |  | MEP |  | 1 |
| A19882 |  | Installation of HVAC Fans | 10d | 2019-05-14 | 2019-05-23 | A19642 | 195.25d | 14d | Mechanical Crew [100 h] | 9.43 |  | MEP |  | 1 |
| A19902 |  | Pressurization Unit | 8d | 2019-05-14 | 2019-05-21 | A19642 | 197.25d | 16d | Mechanical Crew [80 h] | 7.54 |  | MEP |  | 1 |
| A19912 |  | Dosing pot | 5d | 2019-05-14 | 2019-05-19 | A19642 | 200.25d | 19d | Mechanical Crew [50 h] | 4.71 |  | MEP |  | 1 |
| A19932 |  | Air Handling Units Installation | 12d | 2019-05-14 | 2019-05-25 | A19642 | 193.25d | 12d | Mechanical Crew [120 h] | 11.32 |  | MEP |  | 1 |
| A19772 |  | Valves and Accessories | 10d | 2019-05-18 | 2019-05-27 | A19752 | 181.25d | 0d | Mechanical Crew [100 h] | 9.43 |  | MEP |  | 1 |
| A19892 |  | Air-Cooled Chillers | 15d | 2019-05-18 | 2019-06-01 | A19752 | 186.25d | 5d | Mechanical Crew [150 h] | 14.15 |  | MEP |  | 1 |
| A19942 |  | Chilled Water Pump Installation | 12d | 2019-05-18 | 2019-05-28 | A19752 | 189.25d | 8d | Mechanical Crew [120 h] | 11.32 |  | MEP |  | 1 |
| A19782 |  | Chilled Water Pipe Insulation and Cladding | 10d | 2019-05-27 | 2019-06-09 | A19752, A19772 | 181.25d | 0d | Mechanical Crew [100 h] | 9.43 |  | MEP |  | 1 |

| ID | WBS | Activity | Duration | Start | Finish | Predecessors | Total float | Free float | Resources | Cost | Discipline | AREA | MSP Activity ID | MEP-Phase |
| --- | --- | --- | --- | --- | --- | --- | --- | --- | --- | --- | --- | --- | --- | --- |
|  | 1.4.1.4.1.1.4.1.1.-2 | **HVAC_Final Fix** |  | 2019-06-09 | 2019-06-30 |  |  |  |  |  |  |  |  |  |
| A19922 |  | Equuipment Connection | 8d | 2019-06-09 | 2019-06-16 | A19942, A19932, A19892, A19882, A19872, A19842, A19852, A19862, A19912, A19902, A19782 | 181.25d | 0d | Mechanical Crew [80 h] | 7.54 | MEP | 1 |  |  |
| A19762 |  | Air Outlets (Grills, Diffusers, Registers etc...) | 15d | 2019-06-16 | 2019-06-30 | A19742, A19642, A19652, A19922 | 181.25d | 171.75d | Mechanical Crew [150 h] | 14.15 | MEP | 1 |  |  |
|  | 1.4.1.4.1.1.4.1.2 | **PLUMBING SYSTEM** |  | 2019-05-01 | 2019-06-15 |  |  |  |  |  |  |  |  |  |
|  | 1.4.1.4.1.1.4.1.2.1. | **1st Fix** |  | 2019-05-01 | 2019-05-25 |  |  |  |  |  |  |  |  |  |
| A19522 |  | Hanger and support Installation | 10d | 2019-05-01 | 2019-05-09 | RM05 | 198.25d | 0d | Plumbing Crew [100 h] | 9.43 | MEP | 1 | 1566 | CON |
| A19562 |  | Drainage and Vent Pipe & Fittings | 20d | 2019-05-06 | 2019-05-23 | A19522 SS+5d | 210.25d | 1d | Plumbing Crew [200 h] | 18.86 | MEP | 1 | 1573 | CON |
| A19532 |  | Domestic Water Pipe & Fittings | 20d | 2019-05-06 | 2019-05-25 | A19522 SS+6d | 198.25d | 0d | Plumbing Crew [200 h] | 18.86 | MEP | 1 | 1570 | CON |
|  | 1.4.1.4.1.1.4.1.2.-1 | **2nd Fix** |  | 2019-05-25 | 2019-06-12 |  |  |  |  |  |  |  |  |  |
| A19542 |  | Domestic Water Valves | 12d | 2019-05-25 | 2019-06-09 | A19532 | 198.25d | 0d | Plumbing Crew [120 h] | 11.32 | MEP | 1 | 1571 | CON |
| A19802 |  | Sewege Pumps Installation | 5d | 2019-05-25 | 2019-05-29 | A19562, A19532 | 209.25d | 11d | Plumbing Crew [50 h] | 4.71 | MEP | 1 |  |  |
| A19552 |  | Leak Test | 4d | 2019-06-09 | 2019-06-12 | A19542 | 198.25d | 0d | Plumbing Crew [40 h] | 3.77 | MEP | 1 | 1572 | CON |
|  | 1.4.1.4.1.1.4.1.2.-2 | **PLM_Final Fix** |  | 2019-06-12 | 2019-06-15 |  |  |  |  |  |  |  |  |  |
| A19792 |  | Water Heaters | 2d | 2019-06-12 | 2019-06-15 | A19552, A19562, A19532 | 198.25d | 0d | Plumbing Crew [20 h] | 1.89 | MEP | 1 |  |  |
| A19812 |  | Floor Drain | 2d | 2019-06-12 | 2019-06-15 | A19792 SS | 198.25d | 0d | Plumbing Crew [20 h] | 1.89 | MEP | 1 |  |  |
| A19822 |  | Wash Basin / Water Closet | 2d | 2019-06-12 | 2019-06-15 | A19812 SS | 198.25d | 0d | Plumbing Crew [20 h] | 1.89 | MEP | 1 |  |  |
| A19832 |  | Eye Wash | 2d | 2019-06-12 | 2019-06-15 | A19822 SS, A19802 | 198.25d | 175.75d | Plumbing Crew [20 h] | 1.89 | MEP | 1 |  |  |
|  | 1.4.1.4.1.1.4.1.3 | **ELECTRICAL / CONTROLS** |  | 2019-05-01 | 2019-08-27 |  |  |  |  |  |  |  |  |  |
|  | 1.4.1.4.1.1.4.1.3.1. | **1st Fix** |  | 2019-05-01 | 2019-05-27 |  |  |  |  |  |  |  |  |  |
| A19622 |  | Installation of Conduits and Boxes | 12d | 2019-05-01 | 2019-05-12 | RM05 | 122.25d | 0d | Electrical Crew [120 h] | 11.32 | MEP | 1 | 1592 | CON |
| A19632 |  | Installation of Cable Tray, Ladder and Trunk | 20d | 2019-05-08 | 2019-05-27 | A19622 SS+8d | 178.25d | 0d | Electrical Crew [200 h] | 18.86 | MEP | 1 | 1593 | CON |
|  | 1.4.1.4.1.1.4.1.3.-1 | **2nd Fix** |  | 2019-05-12 | 2019-08-13 |  |  |  |  |  |  |  |  |  |
| A19592 |  | Grounding and Bonding Installation | 20d | 2019-05-12 | 2019-05-30 | A19622 | 122.25d | 0d | Electrical Crew [200 h] | 18.86 | MEP | 1 | 1596 | CON |
| A20012 |  | Installation of Bus Duct System | 20d | 2019-05-27 | 2019-06-18 | A19632 | 178.25d | 56d | Electrical Crew [200 h] | 18.86 | MEP | 1 |  |  |
| A19952 |  | Wire Pulling | 20d | 2019-05-30 | 2019-06-22 | A19592 | 122.25d | 0d | Electrical Crew [200 h] | 18.86 | MEP | 1 |  |  |
| A19572 |  | Power Cable Laying | 25d | 2019-06-22 | 2019-07-15 | A19952, A19592 | 122.25d | 0d | Electrical Crew [250 h] | 23.58 | MEP | 1 | 1600 | CON |
| A19582 |  | Continuity Test - Power Cables | 4d | 2019-07-15 | 2019-07-18 | A19572 | 145.25d | 23d | Electrical Crew [40 h] | 3.77 | MEP | 1 | 1601 | CON |
| A19962 |  | Installation of Central Battery Equipment | 6d | 2019-07-15 | 2019-07-21 | A19572, A19952 | 143.25d | 21d | Electrical Crew [60 h] | 5.66 | MEP | 1 |  |  |
| A19972 |  | Installation of Disconnect Switch | 8d | 2019-07-15 | 2019-07-22 | A19572, A19952 | 141.25d | 19d | Electrical Crew [80 h] | 7.54 | MEP | 1 |  |  |
| A19992 |  | Installation of Switch Boards (MDB, EMDB) | 15d | 2019-07-15 | 2019-07-29 | A19572, A19952 | 122.25d | 0d | Electrical Crew [150 h] | 14.15 | MEP | 1 |  |  |
| A20002 |  | Installation of Panel Boards | 15d | 2019-07-15 | 2019-07-29 | A19572, A19952 | 122.25d | 0d | Electrical Crew [150 h] | 14.15 | MEP | 1 |  |  |
| A20022 |  | Installation of MCC | 15d | 2019-07-15 | 2019-07-29 | A19572, A19952 | 122.25d | 0d | Electrical Crew [150 h] | 14.15 | MEP | 1 |  |  |
| A20032 |  | Installation of Lighting Control System | 12d | 2019-07-15 | 2019-07-27 | A19572, A19952 | 125.25d | 3d | Electrical Crew [120 h] | 11.32 | MEP | 1 |  |  |
| A19982 |  | Installation of Wiring Devices and Outlets | 12d | 2019-07-29 | 2019-08-13 | A19952, A20022, A20002, A19992, A20032 | 122.25d | 0d | Electrical Crew [120 h] | 11.32 | MEP | 1 |  |  |

| ID | WBS | Activity | Duration | Start | Finish | Predecessors | Total float | Free float | Resources | Cost | Discipline | AREA | MSP Activity ID | MEP-Phase |
| --- | --- | --- | --- | --- | --- | --- | --- | --- | --- | --- | --- | --- | --- | --- |
|  | 1.4.1.4.1.1.4.1.3.-2 | **Elec._Final Fix** |  | 2019-07-29 | 2019-08-27 |  |  |  |  |  |  |  |  |  |
| A20042 |  | Panel Board Termination | 8d | 2019-07-29 | 2019-08-05 | A19992, A20002, A20022 | 132.25d | 10d | Electrical Crew [80 h] | 7.54 | MEP | 1 |  |  |
| A19612 |  | Wiring devices Termination | 6d | 2019-08-13 | 2019-08-18 | A19962, A19972, A20012, A20032, A19982, A19582 | 122.25d | 0d | Electrical Crew [60 h] | 5.66 | MEP | 1 | 1617 | CON |
| A19602 |  | Lighting Fixtures Installation and Termination | 10d | 2019-08-19 | 2019-08-27 | A19572, A19952, A20042, A19612 | 122.25d | 107.75d | Electrical Crew [100 h] | 9.43 | MEP | 1 | 1616 | CON |
|  | 1.4.1.4.1.1.4.1.4 | **FIRE FIGHTING SYSTEM** |  | 2019-05-01 | 2019-08-05 |  |  |  |  |  |  |  |  |  |
|  | 1.4.1.4.1.1.4.1.4.1. | **1st Fix** |  | 2019-05-01 | 2019-06-15 |  |  |  |  |  |  |  |  |  |
| A19702 |  | Fire Fighting Hangers & Supports | 15d | 2019-05-01 | 2019-05-14 | RM05 | 152.25d | 0d | Fire Fighting Crew [150 h] | 14.15 | MEP | 1 | 1622 | CON |
| A19672 |  | Pipe Installation | 30d | 2019-05-15 | 2019-06-15 | A19702 | 152.25d | 0d | FIRE FIGHTING [180 h]; FF pipe [103 Limt] | 16.97 | MEP | 1 | 1625 | CON |
|  | 1.4.1.4.1.1.4.1.4.-1 | **2nd Fix** |  | 2019-06-16 | 2019-07-13 |  |  |  |  |  |  |  |  |  |
| A19682 |  | Valve and Accessories Installation | 20d | 2019-06-16 | 2019-07-03 | A19672, A19702 | 152.25d | 0d | Fire Fighting Crew [200 h] | 18.86 | MEP | 1 | 1627 | CON |
| A19692 |  | Leak Test | 10d | 2019-07-04 | 2019-07-13 | A19682 | 152.25d | 0d | Fire Fighting Crew [100 h] | 9.43 | MEP | 1 | 1631 | CON |
|  | 1.4.1.4.1.1.4.1.4.-2 | **FF_Final Fix** |  | 2019-07-14 | 2019-08-05 |  |  |  |  |  |  |  |  |  |
| A19712 |  | Installation of Sprinklers | 15d | 2019-07-14 | 2019-07-27 | A19672, A19682, A19692 | 152.25d | 0d | Fire Fighting Crew [150 h] | 14.15 | MEP | 1 | 1633 | CON |
| A19722 |  | Instalaltion of Fire Extinguisher | 10d | 2019-07-28 | 2019-08-05 | A19672, A19712, A20052 FF | 207.25d | 207.75d | Fire Fighting Crew [100 h] | 9.43 | MEP | 1 |  | CON |
| A20052 |  | Installation of Fire hose Cabinet | 5d | 2019-07-28 | 2019-07-31 | A19672, A19712 | 212.25d | 5d | Fire Fighting Crew [50 h] | 4.71 | MEP | 1 |  |  |
|  | 3 | **B07 - UNDER PLATFORM ZONE 03** |  | 2019-04-29 | 2019-08-25 |  |  |  |  |  |  |  |  |  |
|  | 1.4.1.4.1.1.4.1.1 | **HVAC SYSTEM** |  | 2019-04-29 | 2019-06-27 |  |  |  |  |  |  |  |  |  |
|  | 1.4.1.4.1.1.4.1.1.1. | **1st Fix** |  | 2019-04-29 | 2019-05-15 |  |  |  |  |  |  |  |  |  |
| A21822 |  | Hanger and support Installation - Duct | 6d | 2019-04-29 | 2019-05-04 | RM04 | 183.25d | 0d | Mechanical Crew [60 h] | 5.66 | MEP | 2 | 1546 | CON |
| A21892 |  | Hanger and support Installation - CHW | 6d | 2019-04-29 | 2019-05-04 | A21822 SS | 183.25d | 0d | Mechanical Crew [60 h] | 5.66 | MEP | 2 |  |  |
| A21802 |  | Duct Installation | 12d | 2019-04-30 | 2019-05-12 | A21822 SS+2d | 192.75d | 0d | Duct Installation [130 Sqmt]; HVAC [390 h] | 36.78 | MEP | 2 | 1549 | CON |
| A21812 |  | Duct Insulation | 8d | 2019-05-04 | 2019-05-11 | A21802 SS+3d | 216.75d | 33d | Duct Insulation [145 Sqmt]; HVAC [90 h] | 8.49 | MEP | 2 | 1552 | CON |
| A21912 |  | Chilled Water Piping Installation | 12d | 2019-05-04 | 2019-05-15 | A21892 | 183.25d | 0d | Mechanical Crew [120 h] | 11.32 | MEP | 2 |  |  |
|  | 1.4.1.4.1.1.4.1.1.-1 | **2nd Fix** |  | 2019-05-12 | 2019-06-03 |  |  |  |  |  |  |  |  |  |
| A21902 |  | Installation of Duct Accessories (VD, FD, MSD etc....) | 12d | 2019-05-12 | 2019-05-22 | A21802 | 203.75d | 20d | Mechanical Crew [120 h] | 11.32 | MEP | 2 |  |  |
| A22002 |  | CRAC Units Installation | 15d | 2019-05-12 | 2019-05-26 | A21802 | 192.75d | 9d | Mechanical Crew [150 h] | 14.15 | MEP | 2 |  |  |
| A22012 |  | FCU Installation | 15d | 2019-05-12 | 2019-05-26 | A21802 | 192.75d | 9d | Mechanical Crew [150 h] | 14.15 | MEP | 2 |  |  |
| A22022 |  | VRF DX Units Installation | 12d | 2019-05-12 | 2019-05-22 | A21802 | 195.75d | 12d | Mechanical Crew [120 h] | 11.32 | MEP | 2 |  |  |
| A22032 |  | Installation of Attenuators | 10d | 2019-05-12 | 2019-05-21 | A21802 | 197.75d | 14d | Mechanical Crew [100 h] | 9.43 | MEP | 2 |  |  |
| A22042 |  | Installation of HVAC Fans | 10d | 2019-05-12 | 2019-05-21 | A21802 | 197.75d | 14d | Mechanical Crew [100 h] | 9.43 | MEP | 2 |  |  |
| A22062 |  | Pressurization Unit | 8d | 2019-05-12 | 2019-05-19 | A21802 | 199.75d | 16d | Mechanical Crew [80 h] | 7.54 | MEP | 2 |  |  |
| A22072 |  | Dosing pot | 5d | 2019-05-12 | 2019-05-16 | A21802 | 202.75d | 19d | Mechanical Crew [50 h] | 4.71 | MEP | 2 |  |  |
| A22092 |  | Air Handling Units Installation | 12d | 2019-05-12 | 2019-05-22 | A21802 | 195.75d | 12d | Mechanical Crew [120 h] | 11.32 | MEP | 2 |  |  |
| A21932 |  | Valves and Accessories | 10d | 2019-05-15 | 2019-05-25 | A21912 | 183.25d | 0d | Mechanical Crew [100 h] | 9.43 | MEP | 2 |  |  |
| A22052 |  | Air-Cooled Chillers | 15d | 2019-05-15 | 2019-05-29 | A21912 | 188.75d | 5d | Mechanical Crew [150 h] | 14.15 | MEP | 2 |  |  |
| A22102 |  | Chilled Water Pump Installation | 12d | 2019-05-15 | 2019-05-26 | A21912 | 191.75d | 8d | Mechanical Crew [120 h] | 11.32 | MEP | 2 |  |  |
| A21942 |  | Chilled Water Pipe Insulation and Cladding | 10d | 2019-05-25 | 2019-06-03 | A21912, A21932 | 183.25d | 0d | Mechanical Crew [100 h] | 9.43 | MEP | 2 |  |  |

| ID | WBS | Activity | Duration | Start | Finish | Predecessors | Total float | Free float | Resources | Cost | Discipline | AREA | MSP Activity ID | MEP-Phase |
| --- | --- | --- | --- | --- | --- | --- | --- | --- | --- | --- | --- | --- | --- | --- |
|  | 1.4.1.4.1.1.4.1.1.-2 | **HVAC_Final Fix** |  | 2019-06-03 | 2019-06-27 |  |  |  |  |  |  |  |  |  |
| A22082 |  | Equuipment Connection | 8d | 2019-06-03 | 2019-06-13 | A22102, A22092, A22052, A22042, A22032, A22002, A22012, A22022, A22072, A22062, A21942 | 183.75d | 0d | Mechanical Crew [80 h] | 7.54 | MEP | 2 |  |  |
| A21922 |  | Air Outlets (Grills, Diffusers, Registers etc...) | 15d | 2019-06-13 | 2019-06-27 | A21902, A21802, A21812, A22082 | 183.75d | 174.25d | Mechanical Crew [150 h] | 14.15 | MEP | 2 |  |  |
|  | 1.4.1.4.1.1.4.1.2 | **PLUMBING SYSTEM** |  | 2019-04-29 | 2019-06-12 |  |  |  |  |  |  |  |  |  |
|  | 1.4.1.4.1.1.4.1.2.1. | **1st Fix** |  | 2019-04-29 | 2019-05-22 |  |  |  |  |  |  |  |  |  |
| A21682 |  | Hanger and support Installation | 10d | 2019-04-29 | 2019-05-07 | RM04 | 179.25d | 0d | Plumbing Crew [100 h] | 9.43 | MEP | 2 | 1566 | CON |
| A21722 |  | Drainage and Vent Pipe & Fittings | 20d | 2019-05-04 | 2019-05-21 | A21682 SS+5d | 212.75d | 1d | Plumbing Crew [200 h] | 18.86 | MEP | 2 | 1573 | CON |
| A21692 |  | Domestic Water Pipe & Fittings | 20d | 2019-05-04 | 2019-05-22 | A21682 SS+6d | 179.25d | 0d | Plumbing Crew [200 h] | 18.86 | MEP | 2 | 1570 | CON |
|  | 1.4.1.4.1.1.4.1.2.-1 | **2nd Fix** |  | 2019-05-22 | 2019-06-10 |  |  |  |  |  |  |  |  |  |
| A21702 |  | Domestic Water Valves | 12d | 2019-05-22 | 2019-06-03 | A21692 | 179.25d | 0d | Plumbing Crew [120 h] | 11.32 | MEP | 2 | 1571 | CON |
| A21962 |  | Sewege Pumps Installation | 5d | 2019-05-22 | 2019-05-27 | A21722, A21692 | 211.75d | 11d | Plumbing Crew [50 h] | 4.71 | MEP | 2 |  |  |
| A21712 |  | Leak Test | 4d | 2019-06-03 | 2019-06-10 | A21702 | 179.25d | 0d | Plumbing Crew [40 h] | 3.77 | MEP | 2 | 1572 | CON |
|  | 1.4.1.4.1.1.4.1.2.-2 | **PLM_Final Fix** |  | 2019-06-10 | 2019-06-12 |  |  |  |  |  |  |  |  |  |
| A21952 |  | Water Heaters | 2d | 2019-06-10 | 2019-06-12 | A21712, A21722, A21692 | 200.75d | 0d | Plumbing Crew [20 h] | 1.89 | MEP | 2 |  |  |
| A21972 |  | Floor Drain | 2d | 2019-06-10 | 2019-06-12 | A21952 SS | 200.75d | 0d | Plumbing Crew [20 h] | 1.89 | MEP | 2 |  |  |
| A21982 |  | Wash Basin / Water Closet | 2d | 2019-06-10 | 2019-06-12 | A21972 SS | 200.75d | 0d | Plumbing Crew [20 h] | 1.89 | MEP | 2 |  |  |
| A21992 |  | Eye Wash | 2d | 2019-06-10 | 2019-06-12 | A21982 SS, A21962 | 200.75d | 178.25d | Plumbing Crew [20 h] | 1.89 | MEP | 2 |  |  |
|  | 1.4.1.4.1.1.4.1.3 | **ELECTRICAL / CONTROLS** |  | 2019-04-29 | 2019-08-25 |  |  |  |  |  |  |  |  |  |
|  | 1.4.1.4.1.1.4.1.3.1. | **1st Fix** |  | 2019-04-29 | 2019-05-25 |  |  |  |  |  |  |  |  |  |
| A21782 |  | Installation of Conduits and Boxes | 12d | 2019-04-29 | 2019-05-09 | RM04 | 117.25d | 0d | Electrical Crew [120 h] | 11.32 | MEP | 2 | 1592 | CON |
| A21792 |  | Installation of Cable Tray, Ladder and Trunk | 20d | 2019-05-06 | 2019-05-25 | A21782 SS+8d | 180.75d | 0d | Electrical Crew [200 h] | 18.86 | MEP | 2 | 1593 | CON |
|  | 1.4.1.4.1.1.4.1.3.-1 | **2nd Fix** |  | 2019-05-09 | 2019-08-07 |  |  |  |  |  |  |  |  |  |
| A21752 |  | Grounding and Bonding Installation | 20d | 2019-05-09 | 2019-05-28 | A21782 | 117.25d | 0d | Electrical Crew [200 h] | 18.86 | MEP | 2 | 1596 | CON |
| A22172 |  | Installation of Bus Duct System | 20d | 2019-05-25 | 2019-06-16 | A21792 | 180.75d | 56d | Electrical Crew [200 h] | 18.86 | MEP | 2 |  |  |
| A22112 |  | Wire Pulling | 20d | 2019-05-28 | 2019-06-19 | A21752 | 117.25d | 0d | Electrical Crew [200 h] | 18.86 | MEP | 2 |  |  |
| A21732 |  | Power Cable Laying | 25d | 2019-06-19 | 2019-07-13 | A22112, A21752 | 117.25d | 0d | Electrical Crew [250 h] | 23.58 | MEP | 2 | 1600 | CON |
| A21742 |  | Continuity Test - Power Cables | 4d | 2019-07-13 | 2019-07-16 | A21732 | 147.75d | 23d | Electrical Crew [40 h] | 3.77 | MEP | 2 | 1601 | CON |
| A22122 |  | Installation of Central Battery Equipment | 6d | 2019-07-13 | 2019-07-18 | A21732, A22112 | 145.75d | 21d | Electrical Crew [60 h] | 5.66 | MEP | 2 |  |  |
| A22132 |  | Installation of Disconnect Switch | 8d | 2019-07-13 | 2019-07-20 | A21732, A22112 | 143.75d | 19d | Electrical Crew [80 h] | 7.54 | MEP | 2 |  |  |
| A22152 |  | Installation of Switch Boards (MDB, EMDB) | 15d | 2019-07-13 | 2019-07-27 | A21732, A22112 | 117.25d | 0d | Electrical Crew [150 h] | 14.15 | MEP | 2 |  |  |
| A22162 |  | Installation of Panel Boards | 15d | 2019-07-13 | 2019-07-27 | A21732, A22112 | 117.25d | 0d | Electrical Crew [150 h] | 14.15 | MEP | 2 |  |  |
| A22182 |  | Installation of MCC | 15d | 2019-07-13 | 2019-07-27 | A21732, A22112 | 117.25d | 0d | Electrical Crew [150 h] | 14.15 | MEP | 2 |  |  |
| A22192 |  | Installation of Lighting Control System | 12d | 2019-07-13 | 2019-07-24 | A21732, A22112 | 120.25d | 3d | Electrical Crew [120 h] | 11.32 | MEP | 2 |  |  |
| A22142 |  | Installation of Wiring Devices and Outlets | 12d | 2019-07-27 | 2019-08-07 | A22112, A22182, A22162, A22152, A22192 | 117.25d | 0d | Electrical Crew [120 h] | 11.32 | MEP | 2 |  |  |

| ID | WBS | Activity | Duration | Start | Finish | Predecessors | Total float | Free float | Resources | Cost | Discipline | AREA | MSP Activity ID | MEP-Phase |
| --- | --- | --- | --- | --- | --- | --- | --- | --- | --- | --- | --- | --- | --- | --- |
|  | 1.4.1.4.1.1.4.1.3.-2 | **Elec._Final Fix** |  | 2019-07-27 | 2019-08-25 |  |  |  |  |  |  |  |  |  |
| A22202 |  | Panel Board Termination | 8d | 2019-07-27 | 2019-08-03 | A22152, A22162, A22182 | 134.75d | 10d | Electrical Crew [80 h] | 7.54 | MEP | 2 |  |  |
| A21772 |  | Wiring devices Termination | 6d | 2019-08-07 | 2019-08-15 | A22122, A22132, A22172, A22192, A22142, A21742 | 124.75d | 0d | Electrical Crew [60 h] | 5.66 | MEP | 2 | 1617 | CON |
| A21762 |  | Lighting Fixtures Installation and Termination | 10d | 2019-08-17 | 2019-08-25 | A21732, A22112, A22202, A21772 | 124.75d | 110.25d | Electrical Crew [100 h] | 9.43 | MEP | 2 | 1616 | CON |
|  | 1.4.1.4.1.1.4.1.4 | **FIRE FIGHTING SYSTEM** |  | 2019-04-29 | 2019-08-03 |  |  |  |  |  |  |  |  |  |
|  | 1.4.1.4.1.1.4.1.4.1. | **1st Fix** |  | 2019-04-29 | 2019-06-12 |  |  |  |  |  |  |  |  |  |
| A21862 |  | Fire Fighting Hangers & Supports | 15d | 2019-04-29 | 2019-05-12 | RM04 | 146.25d | 0d | Fire Fighting Crew [150 h] | 14.15 | MEP | 2 | 1622 | CON |
| A21832 |  | Pipe Installation | 30d | 2019-05-13 | 2019-06-12 | A21862 | 146.25d | 0d | FF pipe [103 Limt]; FIRE FIGHTING [180 h] | 16.97 | MEP | 2 | 1625 | CON |
|  | 1.4.1.4.1.1.4.1.4.-1 | **2nd Fix** |  | 2019-06-13 | 2019-07-10 |  |  |  |  |  |  |  |  |  |
| A21842 |  | Valve and Accessories Installation | 20d | 2019-06-13 | 2019-07-01 | A21832, A21862 | 146.25d | 0d | Fire Fighting Crew [200 h] | 18.86 | MEP | 2 | 1627 | CON |
| A21852 |  | Leak Test | 10d | 2019-07-02 | 2019-07-10 | A21842 | 146.25d | 0d | Fire Fighting Crew [100 h] | 9.43 | MEP | 2 | 1631 | CON |
|  | 1.4.1.4.1.1.4.1.4.-2 | **FF_Final Fix** |  | 2019-07-11 | 2019-08-03 |  |  |  |  |  |  |  |  |  |
| A21872 |  | Installation of Sprinklers | 15d | 2019-07-11 | 2019-07-24 | A21832, A21842, A21852 | 154.75d | 0d | Fire Fighting Crew [150 h] | 14.15 | MEP | 2 | 1633 | CON |
| A21882 |  | Instalaltion of Fire Extinguisher | 10d | 2019-07-25 | 2019-08-03 | A21832, A21872, A22212 FF | 209.75d | 210.25d | Fire Fighting Crew [100 h] | 9.43 | MEP | 2 |  | CON |
| A22212 |  | Installation of Fire hose Cabinet | 5d | 2019-07-25 | 2019-07-29 | A21832, A21872 | 214.75d | 5d | Fire Fighting Crew [50 h] | 4.71 | MEP | 2 |  |  |
|  | 4 | **B07 - UNDER PLATFORM ZONE 04** |  | 2019-04-29 | 2019-08-25 |  |  |  |  |  |  |  |  |  |
|  | 1.4.1.4.1.1.4.1.1 | **HVAC SYSTEM** |  | 2019-04-29 | 2019-06-27 |  |  |  |  |  |  |  |  |  |
|  | 1.4.1.4.1.1.4.1.1.1. | **1st Fix** |  | 2019-04-29 | 2019-05-15 |  |  |  |  |  |  |  |  |  |
| A23982 |  | Hanger and support Installation - Duct | 6d | 2019-04-29 | 2019-05-04 | RM04 | 183.25d | 0d | Mechanical Crew [60 h] | 5.66 | MEP | 2 | 1546 | CON |
| A24052 |  | Hanger and support Installation - CHW | 6d | 2019-04-29 | 2019-05-04 | A23982 SS | 183.25d | 0d | Mechanical Crew [60 h] | 5.66 | MEP | 2 |  |  |
| A23962 |  | Duct Installation | 12d | 2019-04-30 | 2019-05-12 | A23982 SS+2d | 192.75d | 0d | Duct Installation [130 Sqmt]; HVAC [390 h] | 36.78 | MEP | 2 | 1549 | CON |
| A23972 |  | Duct Insulation | 8d | 2019-05-04 | 2019-05-11 | A23962 SS+3d | 216.75d | 33d | Duct Insulation [145 Sqmt]; HVAC [90 h] | 8.49 | MEP | 2 | 1552 | CON |
| A24072 |  | Chilled Water Piping Installation | 12d | 2019-05-04 | 2019-05-15 | A24052 | 183.25d | 0d | Mechanical Crew [120 h] | 11.32 | MEP | 2 |  |  |
|  | 1.4.1.4.1.1.4.1.1.-1 | **2nd Fix** |  | 2019-05-12 | 2019-06-03 |  |  |  |  |  |  |  |  |  |
| A24062 |  | Installation of Duct Accessories (VD, FD, MSD etc....) | 12d | 2019-05-12 | 2019-05-22 | A23962 | 203.75d | 20d | Mechanical Crew [120 h] | 11.32 | MEP | 2 |  |  |
| A24162 |  | CRAC Units Installation | 15d | 2019-05-12 | 2019-05-26 | A23962 | 192.75d | 9d | Mechanical Crew [150 h] | 14.15 | MEP | 2 |  |  |
| A24172 |  | FCU Installation | 15d | 2019-05-12 | 2019-05-26 | A23962 | 192.75d | 9d | Mechanical Crew [150 h] | 14.15 | MEP | 2 |  |  |
| A24182 |  | VRF DX Units Installation | 12d | 2019-05-12 | 2019-05-22 | A23962 | 195.75d | 12d | Mechanical Crew [120 h] | 11.32 | MEP | 2 |  |  |
| A24192 |  | Installation of Attenuators | 10d | 2019-05-12 | 2019-05-21 | A23962 | 197.75d | 14d | Mechanical Crew [100 h] | 9.43 | MEP | 2 |  |  |
| A24202 |  | Installation of HVAC Fans | 10d | 2019-05-12 | 2019-05-21 | A23962 | 197.75d | 14d | Mechanical Crew [100 h] | 9.43 | MEP | 2 |  |  |
| A24222 |  | Pressurization Unit | 8d | 2019-05-12 | 2019-05-19 | A23962 | 199.75d | 16d | Mechanical Crew [80 h] | 7.54 | MEP | 2 |  |  |
| A24232 |  | Dosing pot | 5d | 2019-05-12 | 2019-05-16 | A23962 | 202.75d | 19d | Mechanical Crew [50 h] | 4.71 | MEP | 2 |  |  |
| A24252 |  | Air Handling Units Installation | 12d | 2019-05-12 | 2019-05-22 | A23962 | 195.75d | 12d | Mechanical Crew [120 h] | 11.32 | MEP | 2 |  |  |
| A24092 |  | Valves and Accessories | 10d | 2019-05-15 | 2019-05-25 | A24072 | 183.25d | 0d | Mechanical Crew [100 h] | 9.43 | MEP | 2 |  |  |
| A24212 |  | Air-Cooled Chillers | 15d | 2019-05-15 | 2019-05-29 | A24072 | 188.75d | 5d | Mechanical Crew [150 h] | 14.15 | MEP | 2 |  |  |
| A24262 |  | Chilled Water Pump Installation | 12d | 2019-05-15 | 2019-05-26 | A24072 | 191.75d | 8d | Mechanical Crew [120 h] | 11.32 | MEP | 2 |  |  |
| A24102 |  | Chilled Water Pipe Insulation and Cladding | 10d | 2019-05-25 | 2019-06-03 | A24072, A24092 | 183.25d | 0d | Mechanical Crew [100 h] | 9.43 | MEP | 2 |  |  |

| ID | WBS | Activity | Duration | Start | Finish | Predecessors | Total float | Free float | Resources | Cost | Discipline | AREA | MSP Activity ID | MEP-Phase |
| --- | --- | --- | --- | --- | --- | --- | --- | --- | --- | --- | --- | --- | --- | --- |
|  | 1.4.1.4.1.1.4.1.1.-2 | **HVAC_Final Fix** |  | 2019-06-03 | 2019-06-27 |  |  |  |  |  |  |  |  |  |
| A24242 |  | Equuipment Connection | 8d | 2019-06-03 | 2019-06-13 | A24262, A24252, A24212, A24202, A24192, A24162, A24172, A24182, A24232, A24222, A24102 | 183.75d | 0d | Mechanical Crew [80 h] | 7.54 | MEP | 2 |  |  |
| A24082 |  | Air Outlets (Grills, Diffusers, Registers etc...) | 15d | 2019-06-13 | 2019-06-27 | A24062, A23962, A23972, A24242 | 183.75d | 174.25d | Mechanical Crew [150 h] | 14.15 | MEP | 2 |  |  |
|  | 1.4.1.4.1.1.4.1.2 | **PLUMBING SYSTEM** |  | 2019-04-29 | 2019-06-12 |  |  |  |  |  |  |  |  |  |
|  | 1.4.1.4.1.1.4.1.2.1. | **1st Fix** |  | 2019-04-29 | 2019-05-22 |  |  |  |  |  |  |  |  |  |
| A23842 |  | Hanger and support Installation | 10d | 2019-04-29 | 2019-05-07 | RM04 | 179.25d | 0d | Plumbing Crew [100 h] | 9.43 | MEP | 2 | 1566 | CON |
| A23882 |  | Drainage and Vent Pipe & Fittings | 20d | 2019-05-04 | 2019-05-21 | A23842 SS+5d | 212.75d | 1d | Plumbing Crew [200 h] | 18.86 | MEP | 2 | 1573 | CON |
| A23852 |  | Domestic Water Pipe & Fittings | 20d | 2019-05-04 | 2019-05-22 | A23842 SS+6d | 179.25d | 0d | Plumbing Crew [200 h] | 18.86 | MEP | 2 | 1570 | CON |
|  | 1.4.1.4.1.1.4.1.2.-1 | **2nd Fix** |  | 2019-05-22 | 2019-06-10 |  |  |  |  |  |  |  |  |  |
| A23862 |  | Domestic Water Valves | 12d | 2019-05-22 | 2019-06-03 | A23852 | 179.25d | 0d | Plumbing Crew [120 h] | 11.32 | MEP | 2 | 1571 | CON |
| A24122 |  | Sewege Pumps Installation | 5d | 2019-05-22 | 2019-05-27 | A23882, A23852 | 211.75d | 11d | Plumbing Crew [50 h] | 4.71 | MEP | 2 |  |  |
| A23872 |  | Leak Test | 4d | 2019-06-03 | 2019-06-10 | A23862 | 179.25d | 0d | Plumbing Crew [40 h] | 3.77 | MEP | 2 | 1572 | CON |
|  | 1.4.1.4.1.1.4.1.2.-2 | **PLM_Final Fix** |  | 2019-06-10 | 2019-06-12 |  |  |  |  |  |  |  |  |  |
| A24112 |  | Water Heaters | 2d | 2019-06-10 | 2019-06-12 | A23872, A23882, A23852 | 200.75d | 0d | Plumbing Crew [20 h] | 1.89 | MEP | 2 |  |  |
| A24132 |  | Floor Drain | 2d | 2019-06-10 | 2019-06-12 | A24112 SS | 200.75d | 0d | Plumbing Crew [20 h] | 1.89 | MEP | 2 |  |  |
| A24142 |  | Wash Basin / Water Closet | 2d | 2019-06-10 | 2019-06-12 | A24132 SS | 200.75d | 0d | Plumbing Crew [20 h] | 1.89 | MEP | 2 |  |  |
| A24152 |  | Eye Wash | 2d | 2019-06-10 | 2019-06-12 | A24142 SS, A24122 | 200.75d | 178.25d | Plumbing Crew [20 h] | 1.89 | MEP | 2 |  |  |
|  | 1.4.1.4.1.1.4.1.3 | **ELECTRICAL / CONTROLS** |  | 2019-04-29 | 2019-08-25 |  |  |  |  |  |  |  |  |  |
|  | 1.4.1.4.1.1.4.1.3.1. | **1st Fix** |  | 2019-04-29 | 2019-05-25 |  |  |  |  |  |  |  |  |  |
| A23942 |  | Installation of Conduits and Boxes | 12d | 2019-04-29 | 2019-05-09 | RM04 | 117.25d | 0d | Electrical Crew [120 h] | 11.32 | MEP | 2 | 1592 | CON |
| A23952 |  | Installation of Cable Tray, Ladder and Trunk | 20d | 2019-05-06 | 2019-05-25 | A23942 SS+8d | 180.75d | 0d | Electrical Crew [200 h] | 18.86 | MEP | 2 | 1593 | CON |
|  | 1.4.1.4.1.1.4.1.3.-1 | **2nd Fix** |  | 2019-05-09 | 2019-08-07 |  |  |  |  |  |  |  |  |  |
| A23912 |  | Grounding and Bonding Installation | 20d | 2019-05-09 | 2019-05-28 | A23942 | 117.25d | 0d | Electrical Crew [200 h] | 18.86 | MEP | 2 | 1596 | CON |
| A24332 |  | Installation of Bus Duct System | 20d | 2019-05-25 | 2019-06-16 | A23952 | 180.75d | 56d | Electrical Crew [200 h] | 18.86 | MEP | 2 |  |  |
| A24272 |  | Wire Pulling | 20d | 2019-05-28 | 2019-06-19 | A23912 | 117.25d | 0d | Electrical Crew [200 h] | 18.86 | MEP | 2 |  |  |
| A23892 |  | Power Cable Laying | 25d | 2019-06-19 | 2019-07-13 | A24272, A23912 | 117.25d | 0d | Electrical Crew [250 h] | 23.58 | MEP | 2 | 1600 | CON |
| A23902 |  | Continuity Test - Power Cables | 4d | 2019-07-13 | 2019-07-16 | A23892 | 147.75d | 23d | Electrical Crew [40 h] | 3.77 | MEP | 2 | 1601 | CON |
| A24282 |  | Installation of Central Battery Equipment | 6d | 2019-07-13 | 2019-07-18 | A23892, A24272 | 145.75d | 21d | Electrical Crew [60 h] | 5.66 | MEP | 2 |  |  |
| A24292 |  | Installation of Disconnect Switch | 8d | 2019-07-13 | 2019-07-20 | A23892, A24272 | 143.75d | 19d | Electrical Crew [80 h] | 7.54 | MEP | 2 |  |  |
| A24312 |  | Installation of Switch Boards (MDB, EMDB) | 15d | 2019-07-13 | 2019-07-27 | A23892, A24272 | 117.25d | 0d | Electrical Crew [150 h] | 14.15 | MEP | 2 |  |  |
| A24322 |  | Installation of Panel Boards | 15d | 2019-07-13 | 2019-07-27 | A23892, A24272 | 117.25d | 0d | Electrical Crew [150 h] | 14.15 | MEP | 2 |  |  |
| A24342 |  | Installation of MCC | 15d | 2019-07-13 | 2019-07-27 | A23892, A24272 | 117.25d | 0d | Electrical Crew [150 h] | 14.15 | MEP | 2 |  |  |
| A24352 |  | Installation of Lighting Control System | 12d | 2019-07-13 | 2019-07-24 | A23892, A24272 | 120.25d | 3d | Electrical Crew [120 h] | 11.32 | MEP | 2 |  |  |
| A24302 |  | Installation of Wiring Devices and Outlets | 12d | 2019-07-27 | 2019-08-07 | A24272, A24342, A24322, A24312, A24352 | 117.25d | 0d | Electrical Crew [120 h] | 11.32 | MEP | 2 |  |  |

| ID | WBS | Activity | Type | Duration | Start | Finish | Predecessors | Total float | Free float | Calendar | Resources | Cost | Discipline | AREA | MSP Activity ID | MEP-Phase | LOCATION |
| --- | --- | --- | --- | --- | --- | --- | --- | --- | --- | --- | --- | --- | --- | --- | --- | --- | --- |
|  | 1.4.1.4.1.1.4.1.3.-2 | **Elec._Final Fix** |  |  | 2019-07-27 | 2019-08-25 |  |  |  |  |  |  |  |  |  |  |  |
| A24362 |  | Panel Board Termination |  | 8d | 2019-07-27 | 2019-08-03 | A24312, A24322, A24342 | 134.75d | 10d |  | Electrical Crew [80 h] | 7.54 | MEP | 2 |  |  |  |
| A23932 |  | Wiring devices Termination |  | 6d | 2019-08-07 | 2019-08-15 | A24282, A24292, A24332, A24352, A24302, A23902 | 124.75d | 0d |  | Electrical Crew [60 h] | 5.66 | MEP | 2 | 1617 | CON |  |
| A23922 |  | Lighting Fixtures Installation and Termination |  | 10d | 2019-08-17 | 2019-08-25 | A23892, A24272, A23932, A24362 | 124.75d | 110.25d |  | Electrical Crew [100 h] | 9.43 | MEP | 2 | 1616 | CON |  |
|  | 1.4.1.4.1.1.4.1.4 | **FIRE FIGHTING SYSTEM** |  |  | 2019-04-29 | 2019-08-03 |  |  |  |  |  |  |  |  |  |  |  |
|  | 1.4.1.4.1.1.4.1.4.1. | **1st Fix** |  |  | 2019-04-29 | 2019-06-12 |  |  |  |  |  |  |  |  |  |  |  |
| A24022 |  | Fire Fighting Hangers & Supports |  | 15d | 2019-04-29 | 2019-05-12 | RM04 | 146.25d | 0d |  | Fire Fighting Crew [150 h] | 14.15 | MEP | 2 | 1622 | CON |  |
| A23992 |  | Pipe Installation |  | 30d | 2019-05-13 | 2019-06-12 | A24022 | 146.25d | 0d |  | FIRE FIGHTING [180 h]; FF pipe [103 Limt] | 16.97 | MEP | 2 | 1625 | CON |  |
|  | 1.4.1.4.1.1.4.1.4.-1 | **2nd Fix** |  |  | 2019-06-13 | 2019-07-10 |  |  |  |  |  |  |  |  |  |  |  |
| A24002 |  | Valve and Accessories Installation |  | 20d | 2019-06-13 | 2019-07-01 | A23992, A24022 | 146.25d | 0d |  | Fire Fighting Crew [200 h] | 18.86 | MEP | 2 | 1627 | CON |  |
| A24012 |  | Leak Test |  | 10d | 2019-07-02 | 2019-07-10 | A24002 | 146.25d | 0d |  | Fire Fighting Crew [100 h] | 9.43 | MEP | 2 | 1631 | CON |  |
|  | 1.4.1.4.1.1.4.1.4.-2 | **FF_Final Fix** |  |  | 2019-07-11 | 2019-08-03 |  |  |  |  |  |  |  |  |  |  |  |
| A24032 |  | Installation of Sprinklers |  | 15d | 2019-07-11 | 2019-07-24 | A23992, A24002, A24012 | 154.75d | 0d |  | Fire Fighting Crew [150 h] | 14.15 | MEP | 2 | 1633 | CON |  |
| A24042 |  | Instalaltion of Fire Extinguisher |  | 10d | 2019-07-25 | 2019-08-03 | A23992, A24032, A24372 FF | 209.75d | 210.25d |  | Fire Fighting Crew [100 h] | 9.43 | MEP | 2 |  | CON |  |
| A24372 |  | Installation of Fire hose Cabinet |  | 5d | 2019-07-25 | 2019-07-29 | A23992, A24032 | 214.75d | 5d |  | Fire Fighting Crew [50 h] | 4.71 | MEP | 2 |  |  |  |
|  | 1.4.2 | **P06 - PLATFORM** |  |  | 2019-01-24 | 2019-10-24 |  |  |  |  |  |  |  |  |  |  |  |
|  | 6 | **SOUTH PLATFORM - SIEMENS ROOM ZONE 4 AND 5** |  |  | 2019-01-24 | 2019-09-03 |  |  |  |  |  |  |  |  |  |  |  |
| LOE-SUM3-070 |  | South . P06 . Siemens Rm - MEP Works; 1st & 2nd Fix | level of effort | 104d | 2019-01-24 | 2019-05-01 | RM25 | 1d | 0d | Saudi |  |  | MEP |  |  |  |  |
| LOE-SUM3-080 |  | South . P06 . Siemens Rm - MEP Works; Final fix | level of effort | 86d | 2019-02-28 | 2019-05-20 | A28562 SS | 3.5d | 0d | Saudi |  |  | MEP |  |  |  |  |
| LOE-SUM3-090 |  | South . P06 - MEP Works; Final fix | level of effort | 153.5d | 2019-04-13 | 2019-09-03 | A30722 SS | 182.25d | 0d | Saudi |  |  | MEP |  |  |  |  |
|  | 1 | **P06 - PLATFORM - SIEMENS ROOM ZONE 04** |  |  | 2019-01-27 | 2019-05-08 |  |  |  |  |  |  |  |  |  |  |  |
|  | 1.4.1.4.1.1.4.1.1 | **HVAC SYSTEM** |  |  | 2019-01-27 | 2019-03-24 |  |  |  |  |  |  |  |  |  |  |  |
|  | 1.4.1.4.1.1.4.1.1.1. | **1st Fix** |  |  | 2019-01-27 | 2019-02-12 |  |  |  |  |  |  |  |  |  |  |  |
| A26142 |  | Hanger and support Installation - Duct |  | 6d | 2019-01-27 | 2019-01-31 | RM15 | 73.25d | 0d |  | Mechanical Crew [60 h] | 5.66 | MEP | 4 | 1546 | CON | MB |
| A26212 |  | Hanger and support Installation - CHW |  | 6d | 2019-01-27 | 2019-01-31 | A26142 SS | 73.25d | 0d |  | Mechanical Crew [60 h] | 5.66 | MEP | 4 |  |  | MB |
| A26122 |  | Duct Installation |  | 12d | 2019-01-28 | 2019-02-09 | A26142 SS+2d, A2232 | 291.5d | 0d |  | Duct Installation [174 Sqmt]; HVAC [520 h] | 49.04 | MEP | 4 | 1549 | CON | MB |
| A26132 |  | Duct Insulation |  | 8d | 2019-01-31 | 2019-02-07 | A26122 SS+3d | 315.5d | 33d |  | Duct Insulation [145 Sqmt]; HVAC [90 h] | 8.49 | MEP | 4 | 1552 | CON | MB |
| A26232 |  | Chilled Water Piping Installation |  | 12d | 2019-01-31 | 2019-02-12 | A26212 | 73.25d | 0d |  | Mechanical Crew [120 h] | 11.32 | MEP | 4 |  |  | MB |

| ID | WBS | Activity | Duration | Start | Finish | Predecessors | Total float | Free float | Resources | Cost | Discipline | AREA | LOCATION | MSP Activity ID | MEP-Phase |
| --- | --- | --- | --- | --- | --- | --- | --- | --- | --- | --- | --- | --- | --- | --- | --- |
|  | 1.4.1.4.1.1.4.1.1.-1 | **2nd Fix** |  | 2019-02-09 | 2019-03-03 |  |  |  |  |  |  |  |  |  |  |
| A26222 |  | Installation of Duct Accessories (VD, FD, MSD etc....) | 12d | 2019-02-09 | 2019-02-19 | A26122 | 302.5d | 20d | Mechanical Crew [120 h] | 11.32 | MEP | 4 | MB |  |  |
| A26322 |  | CRAC Units Installation | 15d | 2019-02-09 | 2019-02-23 | A26122 | 291.5d | 9d | Mechanical Crew [150 h] | 14.15 | MEP | 4 | MB |  |  |
| A26332 |  | FCU Installation | 15d | 2019-02-09 | 2019-02-23 | A26122 | 291.5d | 9d | Mechanical Crew [150 h] | 14.15 | MEP | 4 | MB |  |  |
| A26342 |  | VRF DX Units Installation | 12d | 2019-02-09 | 2019-02-19 | A26122 | 294.5d | 12d | Mechanical Crew [120 h] | 11.32 | MEP | 4 | MB |  |  |
| A26352 |  | Installation of Attenuators | 10d | 2019-02-09 | 2019-02-18 | A26122 | 296.5d | 14d | Mechanical Crew [100 h] | 9.43 | MEP | 4 | MB |  |  |
| A26362 |  | Installation of HVAC Fans | 10d | 2019-02-09 | 2019-02-18 | A26122 | 296.5d | 14d | Mechanical Crew [100 h] | 9.43 | MEP | 4 | MB |  |  |
| A26382 |  | Pressurization Unit | 8d | 2019-02-09 | 2019-02-16 | A26122 | 298.5d | 16d | Mechanical Crew [80 h] | 7.54 | MEP | 4 | MB |  |  |
| A26392 |  | Dosing pot | 5d | 2019-02-09 | 2019-02-13 | A26122 | 301.5d | 19d | Mechanical Crew [50 h] | 4.71 | MEP | 4 | MB |  |  |
| A26412 |  | Air Handling Units Installation | 12d | 2019-02-09 | 2019-02-19 | A26122 | 294.5d | 12d | Mechanical Crew [120 h] | 11.32 | MEP | 4 | MB |  |  |
| A26252 |  | Valves and Accessories | 10d | 2019-02-12 | 2019-02-21 | A26232 | 73.25d | 0d | Mechanical Crew [100 h] | 9.43 | MEP | 4 | MB |  |  |
| A26372 |  | Air-Cooled Chillers | 15d | 2019-02-12 | 2019-02-26 | A26232 | 287.5d | 5d | Mechanical Crew [150 h] | 14.15 | MEP | 4 | MB |  |  |
| A26422 |  | Chilled Water Pump Installation | 12d | 2019-02-12 | 2019-02-23 | A26232 | 290.5d | 8d | Mechanical Crew [120 h] | 11.32 | MEP | 4 | MB |  |  |
| A26262 |  | Chilled Water Pipe Insulation and Cladding | 10d | 2019-02-21 | 2019-03-03 | A26232, A26252 | 73.25d | 0d | Mechanical Crew [100 h] | 9.43 | MEP | 4 | MB |  |  |
|  | 1.4.1.4.1.1.4.1.1.-2 | **HVAC_Final Fix** |  | 2019-03-03 | 2019-03-24 |  |  |  |  |  |  |  |  |  |  |
| A26402 |  | Equuipment Connection | 8d | 2019-03-03 | 2019-03-10 | A26422, A26412, A26372, A26362, A26352, A26322, A26332, A26342, A26392, A26382, A26262 | 282.5d | 0d | Mechanical Crew [80 h] | 7.54 | MEP | 4 | MB |  |  |
| A26242 |  | Air Outlets (Grills, Diffusers, Registers etc...) | 15d | 2019-03-10 | 2019-03-24 | A26222, A26122, A26132, A26402, 1F5-FNS-P06-280 | 282.5d | 273d | Mechanical Crew [150 h] | 14.15 | MEP | 4 | MB |  |  |
|  | 1.4.1.4.1.1.4.1.2 | **PLUMBING SYSTEM** |  | 2019-01-27 | 2019-04-29 |  |  |  |  |  |  |  |  |  |  |
|  | 1.4.1.4.1.1.4.1.2.1. | **1st Fix** |  | 2019-01-27 | 2019-02-19 |  |  |  |  |  |  |  |  |  |  |
| A26002 |  | Hanger and support Installation | 10d | 2019-01-27 | 2019-02-04 | RM15 | 69.25d | 0d | Plumbing Crew [100 h] | 9.43 | MEP | 4 | MB | 1566 | CON |
| A26042 |  | Drainage and Vent Pipe & Fittings | 20d | 2019-01-31 | 2019-02-18 | A26002 SS+5d | 311.5d | 1d | Plumbing Crew [200 h] | 18.86 | MEP | 4 | MB | 1573 | CON |
| A26012 |  | Domestic Water Pipe & Fittings | 20d | 2019-01-31 | 2019-02-19 | A26002 SS+6d | 69.25d | 0d | Plumbing Crew [200 h] | 18.86 | MEP | 4 | MB | 1570 | CON |
|  | 1.4.1.4.1.1.4.1.2.-1 | **2nd Fix** |  | 2019-02-19 | 2019-03-06 |  |  |  |  |  |  |  |  |  |  |
| A26022 |  | Domestic Water Valves | 12d | 2019-02-19 | 2019-03-03 | A26012 | 69.25d | 0d | Plumbing Crew [120 h] | 11.32 | MEP | 4 | MB | 1571 | CON |
| A26282 |  | Sewege Pumps Installation | 5d | 2019-02-19 | 2019-02-24 | A26042, A26012 | 310.5d | 66d | Plumbing Crew [50 h] | 4.71 | MEP | 4 | MB |  |  |
| A26032 |  | Leak Test | 4d | 2019-03-03 | 2019-03-06 | A26022 | 69.25d | 50d | Plumbing Crew [40 h] | 3.77 | MEP | 4 | MB | 1572 | CON |

| ID | WBS | Activity | Duration | Start | Finish | Predecessors | Total float | Free float | Resources | Cost | Discipline | AREA | LOCATION | MSP Activity ID | MEP-Phase |
| --- | --- | --- | --- | --- | --- | --- | --- | --- | --- | --- | --- | --- | --- | --- | --- |
|  | 1.4.1.4.1.1.4.1.2.-2 | **PLM_Final Fix** |  | 2019-04-27 | 2019-04-29 |  |  |  |  |  |  |  |  |  |  |
| A26272 |  | Water Heaters | 2d | 2019-04-27 | 2019-04-29 | A26032, A26042, A26012, 1F5-FNS-P06-290 | 244.5d | 0d | Plumbing Crew [20 h] | 1.89 | MEP | 4 | MB |  |  |
| A26292 |  | Floor Drain | 2d | 2019-04-27 | 2019-04-29 | A26272 SS | 244.5d | 0d | Plumbing Crew [20 h] | 1.89 | MEP | 4 | MB |  |  |
| A26302 |  | Wash Basin / Water Closet | 2d | 2019-04-27 | 2019-04-29 | A26292 SS | 244.5d | 0d | Plumbing Crew [20 h] | 1.89 | MEP | 4 | MB |  |  |
| A26312 |  | Eye Wash | 2d | 2019-04-27 | 2019-04-29 | A26302 SS, A26282 | 244.5d | 222d | Plumbing Crew [20 h] | 1.89 | MEP | 4 | MB |  |  |
|  | 1.4.1.4.1.1.4.1.3 | **ELECTRICAL / CONTROLS** |  | 2019-01-27 | 2019-05-08 |  |  |  |  |  |  |  |  |  |  |
|  | 1.4.1.4.1.1.4.1.3.1. | **1st Fix** |  | 2019-01-27 | 2019-02-25 |  |  |  |  |  |  |  |  |  |  |
| A26102 |  | Installation of Conduits and Boxes | 12d | 2019-01-27 | 2019-02-06 | RM15 | 4.25d | 0d | Electrical Crew [120 h] | 11.32 | MEP | 4 | MB | 1592 | CON |
| A26112 |  | Installation of Cable Tray, Ladder and Trunk | 20d | 2019-02-06 | 2019-02-25 | A26102 | 4.25d | 0d | Electrical Crew [200 h] | 18.86 | MEP | 4 | MB | 1593 | CON |
|  | 1.4.1.4.1.1.4.1.3.-1 | **2nd Fix** |  | 2019-02-06 | 2019-04-22 |  |  |  |  |  |  |  |  |  |  |
| A26072 |  | Grounding and Bonding Installation | 20d | 2019-02-06 | 2019-02-25 | A26102 | 19.25d | 0d | Electrical Crew [200 h] | 18.86 | MEP | 4 | MB | 1596 | CON |
| A26432 |  | Wire Pulling | 20d | 2019-02-25 | 2019-03-16 | A26072 | 19.25d | 0d | Electrical Crew [200 h] | 18.86 | MEP | 4 | MB |  |  |
| A26492 |  | Installation of Bus Duct System | 20d | 2019-02-25 | 2019-03-16 | A26112 | 275.5d | 40d | Electrical Crew [200 h] | 18.86 | MEP | 4 | MB |  |  |
| A26052 |  | Power Cable Laying | 25d | 2019-03-16 | 2019-04-08 | A26432, A26072 | 19.25d | 0d | Electrical Crew [250 h] | 23.58 | MEP | 4 | MB | 1600 | CON |
| A26062 |  | Continuity Test - Power Cables | 4d | 2019-04-08 | 2019-04-11 | A26052 | 246.5d | 11d | Electrical Crew [40 h] | 3.77 | MEP | 4 | MB | 1601 | CON |
| A26442 |  | Installation of Central Battery Equipment | 6d | 2019-04-08 | 2019-04-14 | A26052, A26432 | 244.5d | 9d | Electrical Crew [60 h] | 5.66 | MEP | 4 | MB |  |  |
| A26452 |  | Installation of Disconnect Switch | 8d | 2019-04-08 | 2019-04-15 | A26052, A26432 | 242.5d | 7d | Electrical Crew [80 h] | 7.54 | MEP | 4 | MB |  |  |
| A26472 |  | Installation of Switch Boards (MDB, EMDB) | 15d | 2019-04-08 | 2019-04-22 | A26052, A26432 | 233.5d | 0d | Electrical Crew [150 h] | 14.15 | MEP | 4 | MB |  |  |
| A26482 |  | Installation of Panel Boards | 15d | 2019-04-08 | 2019-04-22 | A26052, A26432 | 233.5d | 0d | Electrical Crew [150 h] | 14.15 | MEP | 4 | MB |  |  |
| A26502 |  | Installation of MCC | 15d | 2019-04-08 | 2019-04-22 | A26052, A26432 | 19.25d | 0d | Electrical Crew [150 h] | 14.15 | MEP | 4 | MB |  |  |
| A26512 |  | Installation of Lighting Control System | 12d | 2019-04-08 | 2019-04-20 | A26052, A26432 | 238.5d | 3d | Electrical Crew [120 h] | 11.32 | MEP | 4 | MB |  |  |
| A26462 |  | Installation of Wiring Devices and Outlets | 12d | 2019-04-11 | 2019-04-22 | A26432, A26502 FF, A26482 FF, A26472 FF, A26512 FF | 235.5d | 0d | Electrical Crew [120 h] | 11.32 | MEP | 4 | MB |  |  |
|  | 1.4.1.4.1.1.4.1.3.-2 | **Elec._Final Fix** |  | 2019-04-22 | 2019-05-08 |  |  |  |  |  |  |  |  |  |  |
| A26092 |  | Wiring devices Termination | 6d | 2019-04-22 | 2019-04-28 | A26442, A26452, A26492, A26512, A26462, A26062 | 235.5d | 2d | Electrical Crew [60 h] | 5.66 | MEP | 4 | MB | 1617 | CON |
| A26522 |  | Panel Board Termination | 8d | 2019-04-22 | 2019-04-29 | A26472, A26482, A26502 | 233.5d | 0d | Electrical Crew [80 h] | 7.54 | MEP | 4 | MB |  |  |
| A26082 |  | Lighting Fixtures Installation and Termination | 10d | 2019-04-30 | 2019-05-08 | A26052, A26432, A26522, A26092, 1F5-FNS-P06-280 | 233.5d | 219d | Electrical Crew [100 h] | 9.43 | MEP | 4 | MB | 1616 | CON |

| ID | WBS | Activity | Duration | Start | Finish | Predecessors | Total float | Free float | Resources | Cost | MSP Activity ID | Discipline | MEP-Phase | AREA | LOCATION |
| --- | --- | --- | --- | --- | --- | --- | --- | --- | --- | --- | --- | --- | --- | --- | --- |
|  | 1.4.1.4.1.1.4.1.4 | **FIRE FIGHTING SYSTEM** |  | 2019-01-27 | 2019-04-29 |  |  |  |  |  |  |  |  |  |  |
|  | 1.4.1.4.1.1.4.1.4.1. | **1st Fix** |  | 2019-01-27 | 2019-03-09 |  |  |  |  |  |  |  |  |  |  |
| A26182 |  | Fire Fighting Hangers & Supports | 15d | 2019-01-27 | 2019-02-09 | RM15 | 36.25d | 0d | Fire Fighting Crew [150 h] | 14.15 | 1622 | MEP | CON | 4 | MB |
| A26152 |  | Pipe Installation | 30d | 2019-02-10 | 2019-03-09 | A26182, A2762 | 36.25d | 0d | FF pipe [137 Limt]; FIRE FIGHTING [241 h] | 22.73 | 1625 | MEP | CON | 4 | MB |
|  | 1.4.1.4.1.1.4.1.4.-1 | **2nd Fix** |  | 2019-03-10 | 2019-04-06 |  |  |  |  |  |  |  |  |  |  |
| A26162 |  | Valve and Accessories Installation | 20d | 2019-03-10 | 2019-03-27 | A26152, A26182 | 36.25d | 0d | Fire Fighting Crew [200 h] | 18.86 | 1627 | MEP | CON | 4 | MB |
| A26172 |  | Leak Test | 10d | 2019-03-28 | 2019-04-06 | A26162 | 36.25d | 0d | Fire Fighting Crew [100 h] | 9.43 | 1631 | MEP | CON | 4 | MB |
|  | 1.4.1.4.1.1.4.1.4.-2 | **FF_Final Fix** |  | 2019-04-07 | 2019-04-29 |  |  |  |  |  |  |  |  |  |  |
| A26192 |  | Installation of Sprinklers | 15d | 2019-04-07 | 2019-04-20 | A26152, A26162, A26172, 1F5-FNS-P06-280 | 253.5d | 0d | Fire Fighting Crew [150 h] | 14.15 | 1633 | MEP | CON | 4 | MB |
| A26202 |  | Instalaltion of Fire Extinguisher | 10d | 2019-04-21 | 2019-04-29 | A26152, A26192, A26532 FF | 308.5d | 309d | Fire Fighting Crew [100 h] | 9.43 |  | MEP | CON | 4 | MB |
| A26532 |  | Installation of Fire hose Cabinet | 5d | 2019-04-21 | 2019-04-24 | A26152, A26192 | 313.5d | 5d | Fire Fighting Crew [50 h] | 4.71 |  | MEP |  | 4 | MB |
|  | 2 | **P06 - PLATFORM - SIEMENS ROOM ZONE 05** |  | 2019-01-24 | 2019-05-20 |  |  |  |  |  |  |  |  |  |  |
|  | 1.4.1.4.1.1.4.1.1 | **HVAC SYSTEM** |  | 2019-01-24 | 2019-05-20 |  |  |  |  |  |  |  |  |  |  |
|  | 1.4.1.4.1.1.4.1.1.1. | **1st Fix** |  | 2019-01-24 | 2019-02-10 |  |  |  |  |  |  |  |  |  |  |
| A28302 |  | Hanger and support Installation - Duct | 6d | 2019-01-24 | 2019-01-29 | RM25 | 66.5d | 0d | Mechanical Crew [60 h] | 5.66 | 1546 | MEP | CON | 5 | MB |
| A28372 |  | Hanger and support Installation - CHW | 6d | 2019-01-24 | 2019-01-29 | A28302 SS | 66.5d | 0d | Mechanical Crew [60 h] | 5.66 |  | MEP |  | 5 | MB |
| A28282 |  | Duct Installation | 12d | 2019-01-26 | 2019-02-06 | A28302 SS+2d | 75.5d | 0d | Duct Installation [174 Sqmt]; HVAC [520 h] | 49.04 | 1549 | MEP | CON | 5 | MB |
| A28292 |  | Duct Insulation | 8d | 2019-01-29 | 2019-02-05 | A28282 SS+3d | 99.5d | 96d | Duct Insulation [145 Sqmt]; HVAC [90 h] | 8.49 | 1552 | MEP | CON | 5 | MB |
| A28392 |  | Chilled Water Piping Installation | 12d | 2019-01-29 | 2019-02-10 | A28372 | 66.5d | 0d | Mechanical Crew [120 h] | 11.32 |  | MEP |  | 5 | MB |
|  | 1.4.1.4.1.1.4.1.1.-1 | **2nd Fix** |  | 2019-02-06 | 2019-02-28 |  |  |  |  |  |  |  |  |  |  |
| A28382 |  | Installation of Duct Accessories (VD, FD, MSD etc....) | 12d | 2019-02-06 | 2019-02-17 | A28282 | 86.5d | 83d | Mechanical Crew [120 h] | 11.32 |  | MEP |  | 5 | MB |
| A28482 |  | CRAC Units Installation | 15d | 2019-02-06 | 2019-02-20 | A28282 | 75.5d | 9d | Mechanical Crew [150 h] | 14.15 |  | MEP |  | 5 | MB |
| A28492 |  | FCU Installation | 15d | 2019-02-06 | 2019-02-20 | A28282 | 75.5d | 9d | Mechanical Crew [150 h] | 14.15 |  | MEP |  | 5 | MB |
| A28502 |  | VRF DX Units Installation | 12d | 2019-02-06 | 2019-02-17 | A28282 | 78.5d | 12d | Mechanical Crew [120 h] | 11.32 |  | MEP |  | 5 | MB |
| A28512 |  | Installation of Attenuators | 10d | 2019-02-06 | 2019-02-16 | A28282 | 80.5d | 14d | Mechanical Crew [100 h] | 9.43 |  | MEP |  | 5 | MB |
| A28522 |  | Installation of HVAC Fans | 10d | 2019-02-06 | 2019-02-16 | A28282 | 80.5d | 14d | Mechanical Crew [100 h] | 9.43 |  | MEP |  | 5 | MB |
| A28542 |  | Pressurization Unit | 8d | 2019-02-06 | 2019-02-13 | A28282 | 82.5d | 16d | Mechanical Crew [80 h] | 7.54 |  | MEP |  | 5 | MB |
| A28552 |  | Dosing pot | 5d | 2019-02-06 | 2019-02-11 | A28282 | 85.5d | 19d | Mechanical Crew [50 h] | 4.71 |  | MEP |  | 5 | MB |
| A28572 |  | Air Handling Units Installation | 12d | 2019-02-06 | 2019-02-17 | A28282 | 78.5d | 12d | Mechanical Crew [120 h] | 11.32 |  | MEP |  | 5 | MB |
| A28412 |  | Valves and Accessories | 10d | 2019-02-10 | 2019-02-19 | A28392 | 66.5d | 0d | Mechanical Crew [100 h] | 9.43 |  | MEP |  | 5 | MB |
| A28532 |  | Air-Cooled Chillers | 15d | 2019-02-10 | 2019-02-24 | A28392 | 71.5d | 5d | Mechanical Crew [150 h] | 14.15 |  | MEP |  | 5 | MB |
| A28582 |  | Chilled Water Pump Installation | 12d | 2019-02-10 | 2019-02-20 | A28392 | 74.5d | 8d | Mechanical Crew [120 h] | 11.32 |  | MEP |  | 5 | MB |
| A28422 |  | Chilled Water Pipe Insulation and Cladding | 10d | 2019-02-19 | 2019-02-28 | A28392, A28412 | 66.5d | 0d | Mechanical Crew [100 h] | 9.43 |  | MEP |  | 5 | MB |

| ID | WBS | Activity | Duration | Start | Finish | Predecessors | Total float | Free float | Resources | Cost | Discipline | AREA | LOCATION | MSP Activity ID | MEP-Phase |
| --- | --- | --- | --- | --- | --- | --- | --- | --- | --- | --- | --- | --- | --- | --- | --- |
|  | 1.4.1.4.1.1.4.1.1.-2 | **HVAC_Final Fix** |  | 2019-02-28 | 2019-05-20 |  |  |  |  |  |  |  |  |  |  |
| A28562 |  | Equuipment Connection | 8d | 2019-02-28 | 2019-03-07 | A28582, A28572, A28532, A28522, A28512, A28482, A28492, A28502, A28552, A28542, A28422 | 66.5d | 63d | Mechanical Crew [80 h] | 7.54 | MEP | 5 | MB |  |  |
| A28402 |  | Air Outlets (Grills, Diffusers, Registers etc...) | 15d | 2019-05-06 | 2019-05-20 | A28382, A28282, A28292, A28562, 1F5-FNS-P06-060A, LOE-SUM3-080 FF | 3.5d | 2.5d | Mechanical Crew [150 h] | 14.15 | MEP | 5 | MB |  |  |
|  | 1.4.1.4.1.1.4.1.2 | **PLUMBING SYSTEM** |  | 2019-01-24 | 2019-05-12 |  |  |  |  |  |  |  |  |  |  |
|  | 1.4.1.4.1.1.4.1.2.1. | **1st Fix** |  | 2019-01-24 | 2019-02-17 |  |  |  |  |  |  |  |  |  |  |
| A28162 |  | Hanger and support Installation | 10d | 2019-01-24 | 2019-02-02 | RM25 | 63d | 0d | Plumbing Crew [100 h] | 9.43 | MEP | 5 | MB | 1566 | CON |
| A28202 |  | Drainage and Vent Pipe & Fittings | 20d | 2019-01-29 | 2019-02-16 | A28162 SS+5d | 95.5d | 1d | Plumbing Crew [200 h] | 18.86 | MEP | 5 | MB | 1573 | CON |
| A28172 |  | Domestic Water Pipe & Fittings | 20d | 2019-01-29 | 2019-02-17 | A28162 SS+6d | 63d | 0d | Plumbing Crew [200 h] | 18.86 | MEP | 5 | MB | 1570 | CON |
|  | 1.4.1.4.1.1.4.1.2.-1 | **2nd Fix** |  | 2019-02-17 | 2019-03-04 |  |  |  |  |  |  |  |  |  |  |
| A28182 |  | Domestic Water Valves | 12d | 2019-02-17 | 2019-02-28 | A28172 | 63d | 0d | Plumbing Crew [120 h] | 11.32 | MEP | 5 | MB | 1571 | CON |
| A28442 |  | Sewege Pumps Installation | 5d | 2019-02-17 | 2019-02-21 | A28202, A28172 | 94.5d | 83d | Plumbing Crew [50 h] | 4.71 | MEP | 5 | MB |  |  |
| A28192 |  | Leak Test | 4d | 2019-02-28 | 2019-03-04 | A28182 | 63d | 62d | Plumbing Crew [40 h] | 3.77 | MEP | 5 | MB | 1572 | CON |
|  | 1.4.1.4.1.1.4.1.2.-2 | **PLM_Final Fix** |  | 2019-05-11 | 2019-05-12 |  |  |  |  |  |  |  |  |  |  |
| A28432 |  | Water Heaters | 2d | 2019-05-11 | 2019-05-12 | A28192, A28202, A28172, 1F5-FNS-P06-070 | 11.5d | 0d | Plumbing Crew [20 h] | 1.89 | MEP | 5 | MB |  |  |
| A28452 |  | Floor Drain | 2d | 2019-05-11 | 2019-05-12 | A28432 SS | 11.5d | 0d | Plumbing Crew [20 h] | 1.89 | MEP | 5 | MB |  |  |
| A28462 |  | Wash Basin / Water Closet | 2d | 2019-05-11 | 2019-05-12 | A28452 SS | 11.5d | 0d | Plumbing Crew [20 h] | 1.89 | MEP | 5 | MB |  |  |
| A28472 |  | Eye Wash | 2d | 2019-05-11 | 2019-05-12 | A28462 SS, A28442 | 11.5d | 10.5d | Plumbing Crew [20 h] | 1.89 | MEP | 5 | MB |  |  |
|  | 1.4.1.4.1.1.4.1.3 | **ELECTRICAL / CONTROLS** |  | 2019-01-24 | 2019-05-15 |  |  |  |  |  |  |  |  |  |  |
|  | 1.4.1.4.1.1.4.1.3.1. | **1st Fix** |  | 2019-01-24 | 2019-02-23 |  |  |  |  |  |  |  |  |  |  |
| A28262 |  | Installation of Conduits and Boxes | 12d | 2019-01-24 | 2019-02-04 | RM25 | 1d | 0d | Electrical Crew [120 h] | 11.32 | MEP | 5 | MB | 1592 | CON |
| A28272 |  | Installation of Cable Tray, Ladder and Trunk | 20d | 2019-02-04 | 2019-02-23 | A28262 | 59.5d | 0d | Electrical Crew [200 h] | 18.86 | MEP | 5 | MB | 1593 | CON |
|  | 1.4.1.4.1.1.4.1.3.-1 | **2nd Fix** |  | 2019-02-04 | 2019-05-01 |  |  |  |  |  |  |  |  |  |  |
| A28232 |  | Grounding and Bonding Installation | 20d | 2019-02-04 | 2019-02-23 | A28262 | 1d | 0d | Electrical Crew [200 h] | 18.86 | MEP | 5 | MB | 1596 | CON |
| A28592 |  | Wire Pulling | 20d | 2019-02-23 | 2019-03-13 | A28232 | 1d | 0d | Electrical Crew [200 h] | 18.86 | MEP | 5 | MB |  |  |
| A28652 |  | Installation of Bus Duct System | 20d | 2019-02-23 | 2019-03-13 | A28272 | 59.5d | 52d | Electrical Crew [200 h] | 18.86 | MEP | 5 | MB |  |  |
| A28212 |  | Power Cable Laying | 25d | 2019-03-13 | 2019-04-06 | A28592, A28232 | 1d | 0d | Electrical Crew [250 h] | 23.58 | MEP | 5 | MB | 1600 | CON |
| A28222 |  | Continuity Test - Power Cables | 4d | 2019-04-06 | 2019-04-09 | A28212 | 30.5d | 23d | Electrical Crew [40 h] | 3.77 | MEP | 5 | MB | 1601 | CON |
| A28602 |  | Installation of Central Battery Equipment | 6d | 2019-04-06 | 2019-04-11 | A28212, A28592 | 28.5d | 21d | Electrical Crew [60 h] | 5.66 | MEP | 5 | MB |  |  |
| A28612 |  | Installation of Disconnect Switch | 8d | 2019-04-06 | 2019-04-13 | A28212, A28592 | 26.5d | 19d | Electrical Crew [80 h] | 7.54 | MEP | 5 | MB |  |  |
| A28632 |  | Installation of Switch Boards (MDB, EMDB) | 15d | 2019-04-06 | 2019-04-20 | A28212, A28592 | 1d | 0d | Electrical Crew [150 h] | 14.15 | MEP | 5 | MB |  |  |
| A28642 |  | Installation of Panel Boards | 15d | 2019-04-06 | 2019-04-20 | A28212, A28592 | 1d | 0d | Electrical Crew [150 h] | 14.15 | MEP | 5 | MB |  |  |
| A28662 |  | Installation of MCC | 15d | 2019-04-06 | 2019-04-20 | A28212, A28592 | 1d | 0d | Electrical Crew [150 h] | 14.15 | MEP | 5 | MB |  |  |
| A28672 |  | Installation of Lighting Control System | 12d | 2019-04-06 | 2019-04-17 | A28212, A28592 | 4d | 3d | Electrical Crew [120 h] | 11.32 | MEP | 5 | MB |  |  |
| A28622 |  | Installation of Wiring Devices and Outlets | 12d | 2019-04-20 | 2019-05-01 | A28592, A28662, A28642, A28632, A28672 | 1d | 0d | Electrical Crew [120 h] | 11.32 | MEP | 5 | MB |  |  |

| ID | WBS | Activity | Duration | Start | Finish | Predecessors | Total float | Free float | Resources | Cost | Discipline | AREA | LOCATION | MSP Activity ID | MEP-Phase |
| --- | --- | --- | --- | --- | --- | --- | --- | --- | --- | --- | --- | --- | --- | --- | --- |
|  | 1.4.1.4.1.1.4.1.3.-2 | **Elec._Final Fix** |  | 2019-04-20 | 2019-05-15 |  |  |  |  |  |  |  |  |  |  |
| A28682 |  | Panel Board Termination | 8d | 2019-04-20 | 2019-04-27 | A28632, A28642, A28662 | 17.5d | 10d | Electrical Crew [80 h] | 7.54 | MEP | 5 | MB |  |  |
| A28252 |  | Wiring devices Termination | 6d | 2019-05-01 | 2019-05-06 | A28602, A28612, A28652, A28672, A28622, A28222 | 7.5d | 0d | Electrical Crew [60 h] | 5.66 | MEP | 5 | MB | 1617 | CON |
| A28242 |  | Lighting Fixtures Installation and Termination | 10d | 2019-05-07 | 2019-05-15 | A28212, A28592, A28682, A28252, 1F5-FNS-P06-060A | 7.5d | 6.5d | Electrical Crew [100 h] | 9.43 | MEP | 5 | MB | 1616 | CON |
|  | 1.4.1.4.1.1.4.1.4 | **FIRE FIGHTING SYSTEM** |  | 2019-01-24 | 2019-05-15 |  |  |  |  |  |  |  |  |  |  |
|  | 1.4.1.4.1.1.4.1.4.1. | **1st Fix** |  | 2019-01-24 | 2019-03-06 |  |  |  |  |  |  |  |  |  |  |
| A28342 |  | Fire Fighting Hangers & Supports | 15d | 2019-01-24 | 2019-02-06 | RM25 | 2.5d | 0d | Fire Fighting Crew [150 h] | 14.15 | MEP | 5 | MB | 1622 | CON |
| A28312 |  | Pipe Installation | 30d | 2019-02-07 | 2019-03-06 | A28342 | 27.5d | 0d | FIRE FIGHTING [241 h]; FF pipe [137 Limt] | 22.73 | MEP | 5 | MB | 1625 | CON |
|  | 1.4.1.4.1.1.4.1.4.-1 | **2nd Fix** |  | 2019-03-07 | 2019-04-03 |  |  |  |  |  |  |  |  |  |  |
| A28322 |  | Valve and Accessories Installation | 20d | 2019-03-07 | 2019-03-25 | A28312, A28342 | 27.5d | 0d | Fire Fighting Crew [200 h] | 18.86 | MEP | 5 | MB | 1627 | CON |
| A28332 |  | Leak Test | 10d | 2019-03-26 | 2019-04-03 | A28322 | 27.5d | 19d | Fire Fighting Crew [100 h] | 9.43 | MEP | 5 | MB | 1631 | CON |
|  | 1.4.1.4.1.1.4.1.4.-2 | **FF_Final Fix** |  | 2019-04-22 | 2019-05-15 |  |  |  |  |  |  |  |  |  |  |
| A28352 |  | Installation of Sprinklers | 15d | 2019-04-22 | 2019-05-06 | A28312, A28322, A28332, 1F5-FNS-P06-060A FF | 8.5d | 0d | Fire Fighting Crew [150 h] | 14.15 | MEP | 5 | MB | 1633 | CON |
| A28362 |  | Instalaltion of Fire Extinguisher | 10d | 2019-05-06 | 2019-05-15 | A28312, A28352, A28692 FF | 8.5d | 7.5d | Fire Fighting Crew [100 h] | 9.43 | MEP | 5 | MB |  | CON |
| A28692 |  | Installation of Fire hose Cabinet | 5d | 2019-05-06 | 2019-05-11 | A28312, A28352 | 13.5d | 5d | Fire Fighting Crew [50 h] | 4.71 | MEP | 5 | MB |  |  |
|  | 3 | **P06 - PLATFORM OUTSIDE SIEMENS ROOM ZONE 4 & 5** |  | 2019-03-09 | 2019-09-03 |  |  |  |  |  |  |  |  |  |  |
|  | 1.4.1.4.1.1.4.1.1 | **HVAC SYSTEM** |  | 2019-03-09 | 2019-08-25 |  |  |  |  |  |  |  |  |  |  |
|  | 1.4.1.4.1.1.4.1.1.1. | **1st Fix** |  | 2019-03-09 | 2019-03-25 |  |  |  |  |  |  |  |  |  |  |
| A30462 |  | Hanger and support Installation - Duct | 6d | 2019-03-09 | 2019-03-13 | RM20 | 223.25d | 0d | Mechanical Crew [60 h] | 5.66 | MEP | 4 | MB | 1546 | CON |
| A30532 |  | Hanger and support Installation - CHW | 6d | 2019-03-09 | 2019-03-13 | A30462 SS | 223.25d | 0d | Mechanical Crew [60 h] | 5.66 | MEP | 4 | MB |  |  |
| A30442 |  | Duct Installation | 12d | 2019-03-10 | 2019-03-21 | A30462 SS+2d | 247.75d | 0d | Duct Installation [174 Sqmt]; HVAC [520 h] | 49.04 | MEP | 4 | MB | 1549 | CON |
| A30452 |  | Duct Insulation | 8d | 2019-03-13 | 2019-03-20 | A30442 SS+3d | 271.75d | 146d | Duct Insulation [145 Sqmt]; HVAC [90 h] | 8.49 | MEP | 4 | MB | 1552 | CON |
| A30552 |  | Chilled Water Piping Installation | 12d | 2019-03-13 | 2019-03-25 | A30532 | 223.25d | 0d | Mechanical Crew [120 h] | 11.32 | MEP | 4 | MB |  |  |
|  | 1.4.1.4.1.1.4.1.1.-1 | **2nd Fix** |  | 2019-03-21 | 2019-04-13 |  |  |  |  |  |  |  |  |  |  |
| A30542 |  | Installation of Duct Accessories (VD, FD, MSD etc....) | 12d | 2019-03-21 | 2019-04-01 | A30442 | 258.75d | 133d | Mechanical Crew [120 h] | 11.32 | MEP | 4 | MB |  |  |
| A30642 |  | CRAC Units Installation | 15d | 2019-03-21 | 2019-04-04 | A30442 | 247.75d | 9d | Mechanical Crew [150 h] | 14.15 | MEP | 4 | MB |  |  |
| A30652 |  | FCU Installation | 15d | 2019-03-21 | 2019-04-04 | A30442 | 247.75d | 9d | Mechanical Crew [150 h] | 14.15 | MEP | 4 | MB |  |  |
| A30662 |  | VRF DX Units Installation | 12d | 2019-03-21 | 2019-04-01 | A30442 | 250.75d | 12d | Mechanical Crew [120 h] | 11.32 | MEP | 4 | MB |  |  |
| A30672 |  | Installation of Attenuators | 10d | 2019-03-21 | 2019-03-31 | A30442 | 252.75d | 14d | Mechanical Crew [100 h] | 9.43 | MEP | 4 | MB |  |  |
| A30682 |  | Installation of HVAC Fans | 10d | 2019-03-21 | 2019-03-31 | A30442 | 252.75d | 14d | Mechanical Crew [100 h] | 9.43 | MEP | 4 | MB |  |  |
| A30702 |  | Pressurization Unit | 8d | 2019-03-21 | 2019-03-28 | A30442 | 254.75d | 16d | Mechanical Crew [80 h] | 7.54 | MEP | 4 | MB |  |  |
| A30712 |  | Dosing pot | 5d | 2019-03-21 | 2019-03-26 | A30442 | 257.75d | 19d | Mechanical Crew [50 h] | 4.71 | MEP | 4 | MB |  |  |
| A30732 |  | Air Handling Units Installation | 12d | 2019-03-21 | 2019-04-01 | A30442 | 250.75d | 12d | Mechanical Crew [120 h] | 11.32 | MEP | 4 | MB |  |  |
| A30572 |  | Valves and Accessories | 10d | 2019-03-25 | 2019-04-03 | A30552 | 223.25d | 0d | Mechanical Crew [100 h] | 9.43 | MEP | 4 | MB |  |  |
| A30692 |  | Air-Cooled Chillers | 15d | 2019-03-25 | 2019-04-08 | A30552 | 243.75d | 5d | Mechanical Crew [150 h] | 14.15 | MEP | 4 | MB |  |  |
| A30742 |  | Chilled Water Pump Installation | 12d | 2019-03-25 | 2019-04-04 | A30552 | 246.75d | 8d | Mechanical Crew [120 h] | 11.32 | MEP | 4 | MB |  |  |
| A30582 |  | Chilled Water Pipe Insulation and Cladding | 10d | 2019-04-03 | 2019-04-13 | A30552, A30572 | 223.25d | 0d | Mechanical Crew [100 h] | 9.43 | MEP | 4 | MB |  |  |

| ID | WBS | Activity | Duration | Start | Finish | Predecessors | Total float | Free float | Resources | Cost | Discipline | AREA | LOCATION | MSP Activity ID | MEP-Phase |
| --- | --- | --- | --- | --- | --- | --- | --- | --- | --- | --- | --- | --- | --- | --- | --- |
|  | 1.4.1.4.1.1.4.1.1.-2 | **HVAC_Final Fix** |  | 2019-04-13 | 2019-08-25 |  |  |  |  |  |  |  |  |  |  |
| A30722 |  | Equuipment Connection | 8d | 2019-04-13 | 2019-04-20 | A30742, A30732, A30692, A30682, A30672, A30642, A30652, A30662, A30712, A30702, A30582 | 238.75d | 113d | Mechanical Crew [80 h] | 7.54 | MEP | 4 | MB |  |  |
| A30562 |  | Air Outlets (Grills, Diffusers, Registers etc...) | 15d | 2019-08-07 | 2019-08-25 | A30542, A30442, A30452, A30722, 1F5-FNS-P06-190 | 125.75d | 116.25d | Mechanical Crew [150 h] | 14.15 | MEP | 4 | MB |  |  |
|  | 1.4.1.4.1.1.4.1.2 | **PLUMBING SYSTEM** |  | 2019-03-09 | 2019-06-25 |  |  |  |  |  |  |  |  |  |  |
|  | 1.4.1.4.1.1.4.1.2.1. | **1st Fix** |  | 2019-03-09 | 2019-04-01 |  |  |  |  |  |  |  |  |  |  |
| A30322 |  | Hanger and support Installation | 10d | 2019-03-09 | 2019-03-17 | RM20 | 219.25d | 0d | Plumbing Crew [100 h] | 9.43 | MEP | 4 | MB | 1566 | CON |
| A30362 |  | Drainage and Vent Pipe & Fittings | 20d | 2019-03-13 | 2019-03-31 | A30322 SS+5d | 267.75d | 1d | Plumbing Crew [200 h] | 18.86 | MEP | 4 | MB | 1573 | CON |
| A30332 |  | Domestic Water Pipe & Fittings | 20d | 2019-03-13 | 2019-04-01 | A30322 SS+6d | 219.25d | 0d | Plumbing Crew [200 h] | 18.86 | MEP | 4 | MB | 1570 | CON |
|  | 1.4.1.4.1.1.4.1.2.-1 | **2nd Fix** |  | 2019-04-01 | 2019-04-16 |  |  |  |  |  |  |  |  |  |  |
| A30342 |  | Domestic Water Valves | 12d | 2019-04-01 | 2019-04-13 | A30332 | 219.25d | 0d | Plumbing Crew [120 h] | 11.32 | MEP | 4 | MB | 1571 | CON |
| A30602 |  | Sewege Pumps Installation | 5d | 2019-04-01 | 2019-04-06 | A30362, A30332 | 266.75d | 80.5d | Plumbing Crew [50 h] | 4.71 | MEP | 4 | MB |  |  |
| A30352 |  | Leak Test | 4d | 2019-04-13 | 2019-04-16 | A30342 | 219.25d | 62d | Plumbing Crew [40 h] | 3.77 | MEP | 4 | MB | 1572 | CON |
|  | 1.4.1.4.1.1.4.1.2.-2 | **PLM_Final Fix** |  | 2019-06-24 | 2019-06-25 |  |  |  |  |  |  |  |  |  |  |
| A30592 |  | Water Heaters | 2d | 2019-06-24 | 2019-06-25 | A30352, A30362, A30332, 1F5-FNS-P06-420, 1F5-FNS-P06-420 FF | 186.25d | 0d | Plumbing Crew [20 h] | 1.89 | MEP | 4 | MB |  |  |
| A30612 |  | Floor Drain | 2d | 2019-06-24 | 2019-06-25 | A30592 SS | 186.25d | 0d | Plumbing Crew [20 h] | 1.89 | MEP | 4 | MB |  |  |
| A30622 |  | Wash Basin / Water Closet | 2d | 2019-06-24 | 2019-06-25 | A30612 SS | 186.25d | 0d | Plumbing Crew [20 h] | 1.89 | MEP | 4 | MB |  |  |
| A30632 |  | Eye Wash | 2d | 2019-06-24 | 2019-06-25 | A30622 SS, A30602 | 186.25d | 163.75d | Plumbing Crew [20 h] | 1.89 | MEP | 4 | MB |  |  |
|  | 1.4.1.4.1.1.4.1.3 | **ELECTRICAL / CONTROLS** |  | 2019-03-09 | 2019-09-01 |  |  |  |  |  |  |  |  |  |  |
|  | 1.4.1.4.1.1.4.1.3.1. | **1st Fix** |  | 2019-03-09 | 2019-04-07 |  |  |  |  |  |  |  |  |  |  |
| A30422 |  | Installation of Conduits and Boxes | 12d | 2019-03-09 | 2019-03-19 | RM20 | 157.25d | 0d | Electrical Crew [120 h] | 11.32 | MEP | 4 | MB | 1592 | CON |
| A30432 |  | Installation of Cable Tray, Ladder and Trunk | 20d | 2019-03-19 | 2019-04-07 | A30422 | 231.75d | 0d | Electrical Crew [200 h] | 18.86 | MEP | 4 | MB | 1593 | CON |
|  | 1.4.1.4.1.1.4.1.3.-1 | **2nd Fix** |  | 2019-03-19 | 2019-06-17 |  |  |  |  |  |  |  |  |  |  |
| A30392 |  | Grounding and Bonding Installation | 20d | 2019-03-19 | 2019-04-07 | A30422 | 157.25d | 0d | Electrical Crew [200 h] | 18.86 | MEP | 4 | MB | 1596 | CON |
| A30752 |  | Wire Pulling | 20d | 2019-04-07 | 2019-04-25 | A30392 | 157.25d | 0d | Electrical Crew [200 h] | 18.86 | MEP | 4 | MB |  |  |
| A30812 |  | Installation of Bus Duct System | 20d | 2019-04-07 | 2019-04-25 | A30432 | 231.75d | 114.5d | Electrical Crew [200 h] | 18.86 | MEP | 4 | MB |  |  |
| A30372 |  | Power Cable Laying | 25d | 2019-04-25 | 2019-05-19 | A30752, A30392 | 157.25d | 0d | Electrical Crew [250 h] | 23.58 | MEP | 4 | MB | 1600 | CON |
| A30382 |  | Continuity Test - Power Cables | 4d | 2019-05-19 | 2019-05-22 | A30372 | 202.75d | 85.5d | Electrical Crew [40 h] | 3.77 | MEP | 4 | MB | 1601 | CON |
| A30762 |  | Installation of Central Battery Equipment | 6d | 2019-05-19 | 2019-05-25 | A30372, A30752 | 200.75d | 83.5d | Electrical Crew [60 h] | 5.66 | MEP | 4 | MB |  |  |
| A30772 |  | Installation of Disconnect Switch | 8d | 2019-05-19 | 2019-05-26 | A30372, A30752 | 198.75d | 81.5d | Electrical Crew [80 h] | 7.54 | MEP | 4 | MB |  |  |
| A30792 |  | Installation of Switch Boards (MDB, EMDB) | 15d | 2019-05-19 | 2019-06-02 | A30372, A30752 | 157.25d | 0d | Electrical Crew [150 h] | 14.15 | MEP | 4 | MB |  |  |
| A30802 |  | Installation of Panel Boards | 15d | 2019-05-19 | 2019-06-02 | A30372, A30752 | 157.25d | 0d | Electrical Crew [150 h] | 14.15 | MEP | 4 | MB |  |  |
| A30822 |  | Installation of MCC | 15d | 2019-05-19 | 2019-06-02 | A30372, A30752 | 157.25d | 0d | Electrical Crew [150 h] | 14.15 | MEP | 4 | MB |  |  |
| A30832 |  | Installation of Lighting Control System | 12d | 2019-05-19 | 2019-05-30 | A30372, A30752 | 160.25d | 3d | Electrical Crew [120 h] | 11.32 | MEP | 4 | MB |  |  |
| A30782 |  | Installation of Wiring Devices and Outlets | 12d | 2019-06-02 | 2019-06-17 | A30752, A30822, A30802, A30792, A30832 | 157.25d | 0d | Electrical Crew [120 h] | 11.32 | MEP | 4 | MB |  |  |

| ID | WBS | Activity | Type | Duration | Start | Finish | Predecessors | Total float | Free float | Calendar | Resources | Cost | Discipline | AREA | LOCATION | MSP Activity ID | MEP-Phase |
| --- | --- | --- | --- | --- | --- | --- | --- | --- | --- | --- | --- | --- | --- | --- | --- | --- | --- |
|  | 1.4.1.4.1.1.4.1.3.-2 | **Elec._Final Fix** |  |  | 2019-06-02 | 2019-09-01 |  |  |  |  |  |  |  |  |  |  |  |
| A30842 |  | Panel Board Termination |  | 8d | 2019-06-02 | 2019-06-12 | A30792, A30802, A30822 | 189.75d | 72.5d |  | Electrical Crew [80 h] | 7.54 | MEP | 4 | MB |  |  |
| A30412 |  | Wiring devices Termination |  | 6d | 2019-08-18 | 2019-08-22 | A30762, A30772, A30812, A30832, A30782, A30382, 1F5-FNS-P06-420, 1F5-FNS-P06-200 | 117.25d | 0d |  | Electrical Crew [60 h] | 5.66 | MEP | 4 | MB | 1617 | CON |
| A30402 |  | Lighting Fixtures Installation and Termination |  | 10d | 2019-08-24 | 2019-09-01 | A30372, A30752, A30842, A30412, 1F5-FNS-P06-190 | 117.25d | 102.75d |  | Electrical Crew [100 h] | 9.43 | MEP | 4 | MB | 1616 | CON |
|  | 1.4.1.4.1.1.4.1.4 | **FIRE FIGHTING SYSTEM** |  |  | 2019-03-09 | 2019-09-03 |  |  |  |  |  |  |  |  |  |  |  |
|  | 1.4.1.4.1.1.4.1.4.1. | **1st Fix** |  |  | 2019-03-09 | 2019-04-18 |  |  |  |  |  |  |  |  |  |  |  |
| A30502 |  | Fire Fighting Hangers & Supports |  | 15d | 2019-03-09 | 2019-03-21 | RM20 | 186.25d | 0d |  | Fire Fighting Crew [150 h] | 14.15 | MEP | 4 | MB | 1622 | CON |
| A30472 |  | Pipe Installation |  | 30d | 2019-03-23 | 2019-04-18 | A30502 | 186.25d | 0d |  | FF pipe [137 Limt]; FIRE FIGHTING [241 h] | 22.73 | MEP | 4 | MB | 1625 | CON |
|  | 1.4.1.4.1.1.4.1.4.-1 | **2nd Fix** |  |  | 2019-04-20 | 2019-05-16 |  |  |  |  |  |  |  |  |  |  |  |
| A30482 |  | Valve and Accessories Installation |  | 20d | 2019-04-20 | 2019-05-07 | A30472, A30502 | 186.25d | 0d |  | Fire Fighting Crew [200 h] | 18.86 | MEP | 4 | MB | 1627 | CON |
| A30492 |  | Leak Test |  | 10d | 2019-05-08 | 2019-05-16 | A30482 | 186.25d | 29d |  | Fire Fighting Crew [100 h] | 9.43 | MEP | 4 | MB | 1631 | CON |
|  | 1.4.1.4.1.1.4.1.4.-2 | **FF_Final Fix** |  |  | 2019-08-07 | 2019-09-03 |  |  |  |  |  |  |  |  |  |  |  |
| A30512 |  | Installation of Sprinklers |  | 15d | 2019-08-07 | 2019-08-25 | A30472, A30482, A30492, 1F5-FNS-P06-190 | 125.75d | 0d |  | Fire Fighting Crew [150 h] | 14.15 | MEP | 4 | MB | 1633 | CON |
| A30522 |  | Instalaltion of Fire Extinguisher |  | 10d | 2019-08-25 | 2019-09-03 | A30472, A30512, A30852 FF, LOE-SUM3-090 FF | 180.75d | 181.25d |  | Fire Fighting Crew [100 h] | 9.43 | MEP | 4 | MB |  | CON |
| A30852 |  | Installation of Fire hose Cabinet |  | 5d | 2019-08-25 | 2019-08-29 | A30472, A30512 | 185.75d | 5d |  | Fire Fighting Crew [50 h] | 4.71 | MEP | 4 | MB |  |  |
|  | 1 | **CENTRAL PLATFORM - SIEMENS ROOM ZONE 03** |  |  | 2019-02-10 | 2019-10-19 |  |  |  |  |  |  |  |  |  |  |  |
| LOE-SUM3-100 |  | Central . P06 . Siemens Rm - MEP Works; 1st & 2nd Fix | level of effort | 92d | 2019-02-10 | 2019-05-06 | RM35 | 5.5d | 0d | Saudi |  |  | MEP |  |  |  |  |
| LOE-SUM3-110 |  | Central . P06 . Siemens Rm - MEP Works; Final fix | level of effort | 107.75d | 2019-03-17 | 2019-06-25 | A32882 SS | 168.75d | 0d | Saudi |  |  | MEP |  |  |  |  |
| LOE-SUM3-120 |  | Central . P06 - MEP Works; Final fix | level of effort | 123.5d | 2019-06-25 | 2019-10-19 | LOE-SUM3-110, A35042 SS | 133.25d | 0d | Saudi |  |  | MEP |  |  |  |  |
|  | 3 | **P06 - PLATFORM - SIEMENS ROOM ZONE 03** |  |  | 2019-02-10 | 2019-06-25 |  |  |  |  |  |  |  |  |  |  |  |
|  | 1.4.1.4.1.1.4.1.1 | **HVAC SYSTEM** |  |  | 2019-02-10 | 2019-05-26 |  |  |  |  |  |  |  |  |  |  |  |
|  | 1.4.1.4.1.1.4.1.1.1. | **1st Fix** |  |  | 2019-02-10 | 2019-02-26 |  |  |  |  |  |  |  |  |  |  |  |
| A32622 |  | Hanger and support Installation - Duct |  | 6d | 2019-02-10 | 2019-02-14 | RM35 | 59.5d | 0d |  | Mechanical Crew [60 h] | 5.66 | MEP | 3 | MB | 1546 | CON |
| A32692 |  | Hanger and support Installation - CHW |  | 6d | 2019-02-10 | 2019-02-14 | A32622 SS | 59.5d | 0d |  | Mechanical Crew [60 h] | 5.66 | MEP | 3 | MB |  |  |
| A32602 |  | Duct Installation |  | 12d | 2019-02-11 | 2019-02-23 | A32622 SS+2d | 276.5d | 0d |  | Duct Installation [260 Sqmt]; HVAC [780 h] | 73.55 | MEP | 3 | MB | 1549 | CON |
| A32612 |  | Duct Insulation |  | 8d | 2019-02-14 | 2019-02-21 | A32602 SS+3d | 300.5d | 85.25d |  | Duct Insulation [260 Sqmt]; HVAC [190 h] | 17.92 | MEP | 3 | MB | 1552 | CON |
| A32712 |  | Chilled Water Piping Installation |  | 12d | 2019-02-14 | 2019-02-26 | A32692 | 59.5d | 0d |  | Mechanical Crew [120 h] | 11.32 | MEP | 3 | MB |  |  |

| ID | WBS | Activity | Duration | Start | Finish | Predecessors | Total float | Free float | Resources | Cost | Discipline | AREA | LOCATION | MSP Activity ID | MEP-Phase |
| --- | --- | --- | --- | --- | --- | --- | --- | --- | --- | --- | --- | --- | --- | --- | --- |
|  | 1.4.1.4.1.1.4.1.1.-1 | **2nd Fix** |  | 2019-02-23 | 2019-03-17 |  |  |  |  |  |  |  |  |  |  |
| A32702 |  | Installation of Duct Accessories (VD, FD, MSD etc....) | 12d | 2019-02-23 | 2019-03-05 | A32602 | 287.5d | 72.25d | Mechanical Crew [120 h] | 11.32 | MEP | 3 | MB |  |  |
| A32802 |  | CRAC Units Installation | 15d | 2019-02-23 | 2019-03-09 | A32602 | 276.5d | 9d | Mechanical Crew [150 h] | 14.15 | MEP | 3 | MB |  |  |
| A32812 |  | FCU Installation | 15d | 2019-02-23 | 2019-03-09 | A32602 | 276.5d | 9d | Mechanical Crew [150 h] | 14.15 | MEP | 3 | MB |  |  |
| A32822 |  | VRF DX Units Installation | 12d | 2019-02-23 | 2019-03-05 | A32602 | 279.5d | 12d | Mechanical Crew [120 h] | 11.32 | MEP | 3 | MB |  |  |
| A32832 |  | Installation of Attenuators | 10d | 2019-02-23 | 2019-03-04 | A32602 | 281.5d | 14d | Mechanical Crew [100 h] | 9.43 | MEP | 3 | MB |  |  |
| A32842 |  | Installation of HVAC Fans | 10d | 2019-02-23 | 2019-03-04 | A32602 | 281.5d | 14d | Mechanical Crew [100 h] | 9.43 | MEP | 3 | MB |  |  |
| A32862 |  | Pressurization Unit | 8d | 2019-02-23 | 2019-03-02 | A32602 | 283.5d | 16d | Mechanical Crew [80 h] | 7.54 | MEP | 3 | MB |  |  |
| A32872 |  | Dosing pot | 5d | 2019-02-23 | 2019-02-27 | A32602 | 286.5d | 19d | Mechanical Crew [50 h] | 4.71 | MEP | 3 | MB |  |  |
| A32892 |  | Air Handling Units Installation | 12d | 2019-02-23 | 2019-03-05 | A32602 | 279.5d | 12d | Mechanical Crew [120 h] | 11.32 | MEP | 3 | MB |  |  |
| A32732 |  | Valves and Accessories | 10d | 2019-02-26 | 2019-03-07 | A32712 | 59.5d | 0d | Mechanical Crew [100 h] | 9.43 | MEP | 3 | MB |  |  |
| A32852 |  | Air-Cooled Chillers | 15d | 2019-02-26 | 2019-03-12 | A32712 | 272.5d | 5d | Mechanical Crew [150 h] | 14.15 | MEP | 3 | MB |  |  |
| A32902 |  | Chilled Water Pump Installation | 12d | 2019-02-26 | 2019-03-09 | A32712 | 275.5d | 8d | Mechanical Crew [120 h] | 11.32 | MEP | 3 | MB |  |  |
| A32742 |  | Chilled Water Pipe Insulation and Cladding | 10d | 2019-03-07 | 2019-03-17 | A32712, A32732 | 59.5d | 0d | Mechanical Crew [100 h] | 9.43 | MEP | 3 | MB |  |  |
|  | 1.4.1.4.1.1.4.1.1.-2 | **HVAC_Final Fix** |  | 2019-03-17 | 2019-05-26 |  |  |  |  |  |  |  |  |  |  |
| A32882 |  | Equuipment Connection | 8d | 2019-03-17 | 2019-03-24 | A32902, A32892, A32852, A32842, A32832, A32802, A32812, A32822, A32872, A32862, A32742 | 267.5d | 52.25d | Mechanical Crew [80 h] | 7.54 | MEP | 3 | MB |  |  |
| A32722 |  | Air Outlets (Grills, Diffusers, Registers etc...) | 15d | 2019-05-12 | 2019-05-26 | A32702, A32602, A32612, A32882, 1F5-FNS-P06-500 | 215.25d | 205.75d | Mechanical Crew [150 h] | 14.15 | MEP | 3 | MB |  |  |
|  | 1.4.1.4.1.1.4.1.2 | **PLUMBING SYSTEM** |  | 2019-02-10 | 2019-05-12 |  |  |  |  |  |  |  |  |  |  |
|  | 1.4.1.4.1.1.4.1.2.1. | **1st Fix** |  | 2019-02-10 | 2019-03-05 |  |  |  |  |  |  |  |  |  |  |
| A32482 |  | Hanger and support Installation | 10d | 2019-02-10 | 2019-02-18 | RM35 | 55.5d | 0d | Plumbing Crew [100 h] | 9.43 | MEP | 3 | MB | 1566 | CON |
| A32522 |  | Drainage and Vent Pipe & Fittings | 20d | 2019-02-14 | 2019-03-04 | A32482 SS+5d | 296.5d | 1d | Plumbing Crew [200 h] | 18.86 | MEP | 3 | MB | 1573 | CON |
| A32492 |  | Domestic Water Pipe & Fittings | 20d | 2019-02-14 | 2019-03-05 | A32482 SS+6d | 55.5d | 0d | Plumbing Crew [200 h] | 18.86 | MEP | 3 | MB | 1570 | CON |
|  | 1.4.1.4.1.1.4.1.2.-1 | **2nd Fix** |  | 2019-03-05 | 2019-03-20 |  |  |  |  |  |  |  |  |  |  |
| A32502 |  | Domestic Water Valves | 12d | 2019-03-05 | 2019-03-17 | A32492 | 55.5d | 0d | Plumbing Crew [120 h] | 11.32 | MEP | 3 | MB | 1571 | CON |
| A32762 |  | Sewege Pumps Installation | 5d | 2019-03-05 | 2019-03-10 | A32522, A32492 | 295.5d | 65.25d | Plumbing Crew [50 h] | 4.71 | MEP | 3 | MB |  |  |
| A32512 |  | Leak Test | 4d | 2019-03-17 | 2019-03-20 | A32502 | 55.5d | 50d | Plumbing Crew [40 h] | 3.77 | MEP | 3 | MB | 1572 | CON |

| ID | WBS | Activity | Duration | Start | Finish | Predecessors | Total float | Free float | Resources | Cost | Discipline | AREA | LOCATION | MSP Activity ID | MEP-Phase |
| --- | --- | --- | --- | --- | --- | --- | --- | --- | --- | --- | --- | --- | --- | --- | --- |
|  | 1.4.1.4.1.1.4.1.2.-2 | **PLM_Final Fix** |  | 2019-05-11 | 2019-05-12 |  |  |  |  |  |  |  |  |  |  |
| A32752 |  | Water Heaters | 2d | 2019-05-11 | 2019-05-12 | A32512, A32522, A32492, 1F5-FNS-P06-500 FF | 230.25d | 0d | Plumbing Crew [20 h] | 1.89 | MEP | 3 | MB |  |  |
| A32772 |  | Floor Drain | 2d | 2019-05-11 | 2019-05-12 | A32752 SS | 230.25d | 0d | Plumbing Crew [20 h] | 1.89 | MEP | 3 | MB |  |  |
| A32782 |  | Wash Basin / Water Closet | 2d | 2019-05-11 | 2019-05-12 | A32772 SS | 230.25d | 0d | Plumbing Crew [20 h] | 1.89 | MEP | 3 | MB |  |  |
| A32792 |  | Eye Wash | 2d | 2019-05-11 | 2019-05-12 | A32782 SS, A32762 | 230.25d | 207.75d | Plumbing Crew [20 h] | 1.89 | MEP | 3 | MB |  |  |
|  | 1.4.1.4.1.1.4.1.3 | **ELECTRICAL / CONTROLS** |  | 2019-02-10 | 2019-06-02 |  |  |  |  |  |  |  |  |  |  |
|  | 1.4.1.4.1.1.4.1.3.1. | **1st Fix** |  | 2019-02-10 | 2019-03-11 |  |  |  |  |  |  |  |  |  |  |
| A32582 |  | Installation of Conduits and Boxes | 12d | 2019-02-10 | 2019-02-20 | RM35 | 5.5d | 0d | Electrical Crew [120 h] | 11.32 | MEP | 3 | MB | 1592 | CON |
| A32592 |  | Installation of Cable Tray, Ladder and Trunk | 20d | 2019-02-20 | 2019-03-11 | A32582 | 79.5d | 0d | Electrical Crew [200 h] | 18.86 | MEP | 3 | MB | 1593 | CON |
|  | 1.4.1.4.1.1.4.1.3.-1 | **2nd Fix** |  | 2019-02-20 | 2019-05-06 |  |  |  |  |  |  |  |  |  |  |
| A32552 |  | Grounding and Bonding Installation | 20d | 2019-02-20 | 2019-03-11 | A32582 | 5.5d | 0d | Electrical Crew [200 h] | 18.86 | MEP | 3 | MB | 1596 | CON |
| A32912 |  | Wire Pulling | 20d | 2019-03-11 | 2019-03-30 | A32552 | 5.5d | 0d | Electrical Crew [200 h] | 18.86 | MEP | 3 | MB |  |  |
| A32972 |  | Installation of Bus Duct System | 20d | 2019-03-11 | 2019-03-30 | A32592 | 79.5d | 52.5d | Electrical Crew [200 h] | 18.86 | MEP | 3 | MB |  |  |
| A32532 |  | Power Cable Laying | 25d | 2019-03-30 | 2019-04-22 | A32912, A32552 | 5.5d | 0d | Electrical Crew [250 h] | 23.58 | MEP | 3 | MB | 1600 | CON |
| A32542 |  | Continuity Test - Power Cables | 4d | 2019-04-22 | 2019-04-25 | A32532 | 50.5d | 23.5d | Electrical Crew [40 h] | 3.77 | MEP | 3 | MB | 1601 | CON |
| A32922 |  | Installation of Central Battery Equipment | 6d | 2019-04-22 | 2019-04-28 | A32532, A32912 | 48.5d | 21.5d | Electrical Crew [60 h] | 5.66 | MEP | 3 | MB |  |  |
| A32932 |  | Installation of Disconnect Switch | 8d | 2019-04-22 | 2019-04-29 | A32532, A32912 | 46.5d | 19.5d | Electrical Crew [80 h] | 7.54 | MEP | 3 | MB |  |  |
| A32952 |  | Installation of Switch Boards (MDB, EMDB) | 15d | 2019-04-22 | 2019-05-06 | A32532, A32912 | 5.5d | 0d | Electrical Crew [150 h] | 14.15 | MEP | 3 | MB |  |  |
| A32962 |  | Installation of Panel Boards | 15d | 2019-04-22 | 2019-05-06 | A32532, A32912 | 5.5d | 0d | Electrical Crew [150 h] | 14.15 | MEP | 3 | MB |  |  |
| A32982 |  | Installation of MCC | 15d | 2019-04-22 | 2019-05-06 | A32532, A32912 | 5.5d | 0d | Electrical Crew [150 h] | 14.15 | MEP | 3 | MB |  |  |
| A32992 |  | Installation of Lighting Control System | 12d | 2019-04-22 | 2019-05-04 | A32532, A32912 | 8.5d | 3d | Electrical Crew [120 h] | 11.32 | MEP | 3 | MB |  |  |
| A32942 |  | Installation of Wiring Devices and Outlets | 12d | 2019-04-25 | 2019-05-06 | A32912, A32982 FF, A32962 FF, A32952 FF, A32992 FF | 5.5d | 0d | Electrical Crew [120 h] | 11.32 | MEP | 3 | MB |  |  |
|  | 1.4.1.4.1.1.4.1.3.-2 | **Elec._Final Fix** |  | 2019-05-06 | 2019-06-02 |  |  |  |  |  |  |  |  |  |  |
| A33002 |  | Panel Board Termination | 8d | 2019-05-06 | 2019-05-13 | A32952, A32962, A32982 | 37.5d | 10.5d | Electrical Crew [80 h] | 7.54 | MEP | 3 | MB |  |  |
| A32572 |  | Wiring devices Termination | 6d | 2019-05-18 | 2019-05-23 | A32922, A32932, A32972, A32992, A32942, A32542, 1F5-FNS-P06-510 | 27d | 0d | Electrical Crew [60 h] | 5.66 | MEP | 3 | MB | 1617 | CON |
| A32562 |  | Lighting Fixtures Installation and Termination | 10d | 2019-05-23 | 2019-06-02 | A32532, A32912, A33002, A32572, 1F5-FNS-P06-500 | 27d | 21.5d | Electrical Crew [100 h] | 9.43 | MEP | 3 | MB | 1616 | CON |

| ID | WBS | Activity | Duration | Start | Finish | Predecessors | Total float | Free float | Resources | Cost | MSP Activity ID | Discipline | MEP-Phase | AREA | LOCATION |
| --- | --- | --- | --- | --- | --- | --- | --- | --- | --- | --- | --- | --- | --- | --- | --- |
|  | 1.4.1.4.1.1.4.1.4 | **FIRE FIGHTING SYSTEM** |  | 2019-02-10 | 2019-06-25 |  |  |  |  |  |  |  |  |  |  |
|  | 1.4.1.4.1.1.4.1.4.1. | **1st Fix** |  | 2019-02-10 | 2019-03-23 |  |  |  |  |  |  |  |  |  |  |
| A32662 |  | Fire Fighting Hangers & Supports | 15d | 2019-02-10 | 2019-02-23 | RM35 | 22.5d | 0d | Fire Fighting Crew [150 h] | 14.15 | 1622 | MEP | CON | 3 | MB |
| A32632 |  | Pipe Installation | 30d | 2019-02-24 | 2019-03-23 | A32662 | 22.5d | 0d | FIRE FIGHTING [361 h]; FF pipe [206 Limt] | 34.04 | 1625 | MEP | CON | 3 | MB |
|  | 1.4.1.4.1.1.4.1.4.-1 | **2nd Fix** |  | 2019-03-24 | 2019-04-20 |  |  |  |  |  |  |  |  |  |  |
| A32642 |  | Valve and Accessories Installation | 20d | 2019-03-24 | 2019-04-10 | A32632, A32662 | 22.5d | 0d | Fire Fighting Crew [200 h] | 18.86 | 1627 | MEP | CON | 3 | MB |
| A32652 |  | Leak Test | 10d | 2019-04-11 | 2019-04-20 | A32642 | 22.5d | 17d | Fire Fighting Crew [100 h] | 9.43 | 1631 | MEP | CON | 3 | MB |
|  | 1.4.1.4.1.1.4.1.4.-2 | **FF_Final Fix** |  | 2019-05-18 | 2019-06-25 |  |  |  |  |  |  |  |  |  |  |
| A32672 |  | Installation of Sprinklers | 20d | 2019-05-18 | 2019-06-09 | A32632, A32642, A32652, 1F5-FNS-P06-500, 1F5-FNS-P06-510 | 5.5d | 0d | Fire Fighting Crew [200 h] | 18.86 | 1633 | MEP | CON | 3 | MB |
| A32682 |  | Instalaltion of Fire Extinguisher | 10d | 2019-06-09 | 2019-06-18 | A32632, A32672 | 5.5d | 0d | Fire Fighting Crew [100 h] | 9.43 |  | MEP | CON | 3 | MB |
| A33012 |  | Installation of Fire hose Cabinet | 7.5d | 2019-06-18 | 2019-06-25 | A32632, A32672, A32682, LOE-SUM3-110 FF | 5.5d | 0d | Fire Fighting Crew [75 h] | 7.07 |  | MEP |  | 3 | MB |
|  | 1 | **P06 - PLATFORM OUTSIDE SIEMENS ROOM ZONE 03** |  | 2019-06-09 | 2019-10-19 |  |  |  |  |  |  |  |  |  |  |
|  | 1.4.1.4.1.1.4.1.1 | **HVAC SYSTEM** |  | 2019-06-09 | 2019-10-09 |  |  |  |  |  |  |  |  |  |  |
|  | 1.4.1.4.1.1.4.1.1.1. | **1st Fix** |  | 2019-06-09 | 2019-06-25 |  |  |  |  |  |  |  |  |  |  |
| A34782 |  | Hanger and support Installation - Duct | 6d | 2019-06-09 | 2019-06-13 | RM30 | 128.25d | 0d | Mechanical Crew [60 h] | 5.66 | 1546 | MEP | CON | 3 | MB |
| A34852 |  | Hanger and support Installation - CHW | 6d | 2019-06-09 | 2019-06-13 | A34782 SS | 128.25d | 0d | Mechanical Crew [60 h] | 5.66 |  | MEP |  | 3 | MB |
| A34762 |  | Duct Installation | 12d | 2019-06-10 | 2019-06-22 | A34782 SS+2d | 152.75d | 0d | Duct Installation [260 Sqmt]; HVAC [780 h] | 73.55 | 1549 | MEP | CON | 3 | MB |
| A34772 |  | Duct Insulation | 8d | 2019-06-13 | 2019-06-20 | A34762 SS+3d | 176.75d | 98.5d | Duct Insulation [260 Sqmt]; HVAC [190 h] | 17.92 | 1552 | MEP | CON | 3 | MB |
| A34872 |  | Chilled Water Piping Installation | 12d | 2019-06-13 | 2019-06-25 | A34852 | 128.25d | 0d | Mechanical Crew [120 h] | 11.32 |  | MEP |  | 3 | MB |
|  | 1.4.1.4.1.1.4.1.1.-1 | **2nd Fix** |  | 2019-06-22 | 2019-07-14 |  |  |  |  |  |  |  |  |  |  |
| A34862 |  | Installation of Duct Accessories (VD, FD, MSD etc....) | 12d | 2019-06-22 | 2019-07-02 | A34762 | 163.75d | 85.5d | Mechanical Crew [120 h] | 11.32 |  | MEP |  | 3 | MB |
| A34962 |  | CRAC Units Installation | 15d | 2019-06-22 | 2019-07-06 | A34762 | 152.75d | 9d | Mechanical Crew [150 h] | 14.15 |  | MEP |  | 3 | MB |
| A34972 |  | FCU Installation | 15d | 2019-06-22 | 2019-07-06 | A34762 | 152.75d | 9d | Mechanical Crew [150 h] | 14.15 |  | MEP |  | 3 | MB |
| A34982 |  | VRF DX Units Installation | 12d | 2019-06-22 | 2019-07-02 | A34762 | 155.75d | 12d | Mechanical Crew [120 h] | 11.32 |  | MEP |  | 3 | MB |
| A34992 |  | Installation of Attenuators | 10d | 2019-06-22 | 2019-07-01 | A34762 | 157.75d | 14d | Mechanical Crew [100 h] | 9.43 |  | MEP |  | 3 | MB |
| A35002 |  | Installation of HVAC Fans | 10d | 2019-06-22 | 2019-07-01 | A34762 | 157.75d | 14d | Mechanical Crew [100 h] | 9.43 |  | MEP |  | 3 | MB |
| A35022 |  | Pressurization Unit | 8d | 2019-06-22 | 2019-06-29 | A34762 | 159.75d | 16d | Mechanical Crew [80 h] | 7.54 |  | MEP |  | 3 | MB |
| A35032 |  | Dosing pot | 5d | 2019-06-22 | 2019-06-26 | A34762 | 162.75d | 19d | Mechanical Crew [50 h] | 4.71 |  | MEP |  | 3 | MB |
| A35052 |  | Air Handling Units Installation | 12d | 2019-06-22 | 2019-07-02 | A34762 | 155.75d | 12d | Mechanical Crew [120 h] | 11.32 |  | MEP |  | 3 | MB |
| A34892 |  | Valves and Accessories | 10d | 2019-06-25 | 2019-07-04 | A34872 | 128.25d | 0d | Mechanical Crew [100 h] | 9.43 |  | MEP |  | 3 | MB |
| A35012 |  | Air-Cooled Chillers | 15d | 2019-06-25 | 2019-07-09 | A34872 | 148.75d | 5d | Mechanical Crew [150 h] | 14.15 |  | MEP |  | 3 | MB |
| A35062 |  | Chilled Water Pump Installation | 12d | 2019-06-25 | 2019-07-06 | A34872 | 151.75d | 8d | Mechanical Crew [120 h] | 11.32 |  | MEP |  | 3 | MB |
| A34902 |  | Chilled Water Pipe Insulation and Cladding | 10d | 2019-07-04 | 2019-07-14 | A34872, A34892 | 128.25d | 0d | Mechanical Crew [100 h] | 9.43 |  | MEP |  | 3 | MB |

| ID | WBS | Activity | Duration | Start | Finish | Predecessors | Total float | Free float | Resources | Cost | Discipline | AREA | LOCATION | MSP Activity ID | MEP-Phase |
| --- | --- | --- | --- | --- | --- | --- | --- | --- | --- | --- | --- | --- | --- | --- | --- |
|  | 1.4.1.4.1.1.4.1.1.-2 | **HVAC_Final Fix** |  | 2019-07-14 | 2019-10-09 |  |  |  |  |  |  |  |  |  |  |
| A35042 |  | Equuipment Connection | 8d | 2019-07-14 | 2019-07-21 | A35062, A35052, A35012, A35002, A34992, A34962, A34972, A34982, A35032, A35022, A34902 | 143.75d | 65.5d | Mechanical Crew [80 h] | 7.54 | MEP | 3 | MB |  |  |
| A34882 |  | Air Outlets (Grills, Diffusers, Registers etc...) | 15d | 2019-09-25 | 2019-10-09 | A34862, A34762, A34772, A35042, 1F5-FNS-P06-630 | 78.25d | 68.75d | Mechanical Crew [150 h] | 14.15 | MEP | 3 | MB |  |  |
|  | 1.4.1.4.1.1.4.1.2 | **PLUMBING SYSTEM** |  | 2019-06-09 | 2019-10-03 |  |  |  |  |  |  |  |  |  |  |
|  | 1.4.1.4.1.1.4.1.2.1. | **1st Fix** |  | 2019-06-09 | 2019-07-02 |  |  |  |  |  |  |  |  |  |  |
| A34642 |  | Hanger and support Installation | 10d | 2019-06-09 | 2019-06-17 | RM30 | 124.25d | 0d | Plumbing Crew [100 h] | 9.43 | MEP | 3 | MB | 1566 | CON |
| A34682 |  | Drainage and Vent Pipe & Fittings | 20d | 2019-06-13 | 2019-07-01 | A34642 SS+5d | 172.75d | 1d | Plumbing Crew [200 h] | 18.86 | MEP | 3 | MB | 1573 | CON |
| A34652 |  | Domestic Water Pipe & Fittings | 20d | 2019-06-13 | 2019-07-02 | A34642 SS+6d | 124.25d | 0d | Plumbing Crew [200 h] | 18.86 | MEP | 3 | MB | 1570 | CON |
|  | 1.4.1.4.1.1.4.1.2.-1 | **2nd Fix** |  | 2019-07-02 | 2019-07-17 |  |  |  |  |  |  |  |  |  |  |
| A34662 |  | Domestic Water Valves | 12d | 2019-07-02 | 2019-07-14 | A34652 | 124.25d | 0d | Plumbing Crew [120 h] | 11.32 | MEP | 3 | MB | 1571 | CON |
| A34922 |  | Sewege Pumps Installation | 5d | 2019-07-02 | 2019-07-07 | A34682, A34652 | 171.75d | 88d | Plumbing Crew [50 h] | 4.71 | MEP | 3 | MB |  |  |
| A34672 |  | Leak Test | 4d | 2019-07-14 | 2019-07-17 | A34662 | 124.25d | 62d | Plumbing Crew [40 h] | 3.77 | MEP | 3 | MB | 1572 | CON |
|  | 1.4.1.4.1.1.4.1.2.-2 | **PLM_Final Fix** |  | 2019-10-02 | 2019-10-03 |  |  |  |  |  |  |  |  |  |  |
| A34912 |  | Water Heaters | 2d | 2019-10-02 | 2019-10-03 | A34672, A34682, A34652, 1F5-FNS-P06-640 | 83.75d | 0d | Plumbing Crew [20 h] | 1.89 | MEP | 3 | MB |  |  |
| A34932 |  | Floor Drain | 2d | 2019-10-02 | 2019-10-03 | A34912 SS | 83.75d | 0d | Plumbing Crew [20 h] | 1.89 | MEP | 3 | MB |  |  |
| A34942 |  | Wash Basin / Water Closet | 2d | 2019-10-02 | 2019-10-03 | A34932 SS | 83.75d | 0d | Plumbing Crew [20 h] | 1.89 | MEP | 3 | MB |  |  |
| A34952 |  | Eye Wash | 2d | 2019-10-02 | 2019-10-03 | A34942 SS, A34922 | 83.75d | 61.25d | Plumbing Crew [20 h] | 1.89 | MEP | 3 | MB |  |  |
|  | 1.4.1.4.1.1.4.1.3 | **ELECTRICAL / CONTROLS** |  | 2019-06-09 | 2019-10-17 |  |  |  |  |  |  |  |  |  |  |
|  | 1.4.1.4.1.1.4.1.3.1. | **1st Fix** |  | 2019-06-09 | 2019-07-08 |  |  |  |  |  |  |  |  |  |  |
| A34742 |  | Installation of Conduits and Boxes | 12d | 2019-06-09 | 2019-06-19 | RM30 | 62.25d | 0d | Electrical Crew [120 h] | 11.32 | MEP | 3 | MB | 1592 | CON |
| A34752 |  | Installation of Cable Tray, Ladder and Trunk | 20d | 2019-06-19 | 2019-07-08 | A34742 | 136.75d | 0d | Electrical Crew [200 h] | 18.86 | MEP | 3 | MB | 1593 | CON |
|  | 1.4.1.4.1.1.4.1.3.-1 | **2nd Fix** |  | 2019-06-19 | 2019-09-17 |  |  |  |  |  |  |  |  |  |  |
| A34712 |  | Grounding and Bonding Installation | 20d | 2019-06-19 | 2019-07-08 | A34742 | 62.25d | 0d | Electrical Crew [200 h] | 18.86 | MEP | 3 | MB | 1596 | CON |
| A35072 |  | Wire Pulling | 20d | 2019-07-08 | 2019-07-27 | A34712 | 62.25d | 0d | Electrical Crew [200 h] | 18.86 | MEP | 3 | MB |  |  |
| A35132 |  | Installation of Bus Duct System | 20d | 2019-07-08 | 2019-07-27 | A34752 | 136.75d | 67d | Electrical Crew [200 h] | 18.86 | MEP | 3 | MB |  |  |
| A34692 |  | Power Cable Laying | 25d | 2019-07-27 | 2019-08-22 | A35072, A34712 | 62.25d | 0d | Electrical Crew [250 h] | 23.58 | MEP | 3 | MB | 1600 | CON |
| A34702 |  | Continuity Test - Power Cables | 4d | 2019-08-22 | 2019-08-26 | A34692 | 107.75d | 38d | Electrical Crew [40 h] | 3.77 | MEP | 3 | MB | 1601 | CON |
| A35082 |  | Installation of Central Battery Equipment | 6d | 2019-08-22 | 2019-08-28 | A34692, A35072 | 105.75d | 36d | Electrical Crew [60 h] | 5.66 | MEP | 3 | MB |  |  |
| A35092 |  | Installation of Disconnect Switch | 8d | 2019-08-22 | 2019-08-29 | A34692, A35072 | 103.75d | 34d | Electrical Crew [80 h] | 7.54 | MEP | 3 | MB |  |  |
| A35112 |  | Installation of Switch Boards (MDB, EMDB) | 15d | 2019-08-22 | 2019-09-05 | A34692, A35072 | 62.25d | 0d | Electrical Crew [150 h] | 14.15 | MEP | 3 | MB |  |  |
| A35122 |  | Installation of Panel Boards | 15d | 2019-08-22 | 2019-09-05 | A34692, A35072 | 62.25d | 0d | Electrical Crew [150 h] | 14.15 | MEP | 3 | MB |  |  |
| A35142 |  | Installation of MCC | 15d | 2019-08-22 | 2019-09-05 | A34692, A35072 | 62.25d | 0d | Electrical Crew [150 h] | 14.15 | MEP | 3 | MB |  |  |
| A35152 |  | Installation of Lighting Control System | 12d | 2019-08-22 | 2019-09-03 | A34692, A35072 | 65.25d | 3d | Electrical Crew [120 h] | 11.32 | MEP | 3 | MB |  |  |
| A35102 |  | Installation of Wiring Devices and Outlets | 12d | 2019-09-05 | 2019-09-17 | A35072, A35142, A35122, A35112, A35152 | 62.25d | 0d | Electrical Crew [120 h] | 11.32 | MEP | 3 | MB |  |  |

| ID | WBS | Activity | Type | Duration | Start | Finish | Predecessors | Total float | Free float | Calendar | Resources | Cost | Discipline | AREA | LOCATION | MSP Activity ID | MEP-Phase |
| --- | --- | --- | --- | --- | --- | --- | --- | --- | --- | --- | --- | --- | --- | --- | --- | --- | --- |
|  | 1.4.1.4.1.1.4.1.3.-2 | **Elec._Final Fix** |  |  | 2019-09-05 | 2019-10-17 |  |  |  |  |  |  |  |  |  |  |  |
| A35162 |  | Panel Board Termination |  | 8d | 2019-09-05 | 2019-09-12 | A35112, A35122, A35142 | 94.75d | 25d |  | Electrical Crew [80 h] | 7.54 | MEP | 3 | MB |  |  |
| A34732 |  | Wiring devices Termination |  | 6d | 2019-10-02 | 2019-10-08 | A35082, A35092, A35132, A35152, A35102, A34702, 1F5-FNS-P06-640 | 69.75d | 0d |  | Electrical Crew [60 h] | 5.66 | MEP | 3 | MB | 1617 | CON |
| A34722 |  | Lighting Fixtures Installation and Termination |  | 10d | 2019-10-08 | 2019-10-17 | A34692, A35072, A35162, A34732, 1F5-FNS-P06-630, LOE-SUM3-120 FF | 69.75d | 55.25d |  | Electrical Crew [100 h] | 9.43 | MEP | 3 | MB | 1616 | CON |
|  | 1.4.1.4.1.1.4.1.4 | **FIRE FIGHTING SYSTEM** |  |  | 2019-06-09 | 2019-10-19 |  |  |  |  |  |  |  |  |  |  |  |
|  | 1.4.1.4.1.1.4.1.4.1. | **1st Fix** |  |  | 2019-06-09 | 2019-07-20 |  |  |  |  |  |  |  |  |  |  |  |
| A34822 |  | Fire Fighting Hangers & Supports |  | 15d | 2019-06-09 | 2019-06-22 | RM30 | 91.25d | 0d |  | Fire Fighting Crew [150 h] | 14.15 | MEP | 3 | MB | 1622 | CON |
| A34792 |  | Pipe Installation |  | 30d | 2019-06-23 | 2019-07-20 | A34822 | 91.25d | 0d |  | FF pipe [206 Limt]; FIRE FIGHTING [361 h] | 34.04 | MEP | 3 | MB | 1625 | CON |
|  | 1.4.1.4.1.1.4.1.4.-1 | **2nd Fix** |  |  | 2019-07-21 | 2019-08-20 |  |  |  |  |  |  |  |  |  |  |  |
| A34802 |  | Valve and Accessories Installation |  | 20d | 2019-07-21 | 2019-08-07 | A34792, A34822 | 91.25d | 0d |  | Fire Fighting Crew [200 h] | 18.86 | MEP | 3 | MB | 1627 | CON |
| A34812 |  | Leak Test |  | 10d | 2019-08-08 | 2019-08-20 | A34802 | 91.25d | 29d |  | Fire Fighting Crew [100 h] | 9.43 | MEP | 3 | MB | 1631 | CON |
|  | 1.4.1.4.1.1.4.1.4.-2 | **FF_Final Fix** |  |  | 2019-09-25 | 2019-10-19 |  |  |  |  |  |  |  |  |  |  |  |
| A34832 |  | Installation of Sprinklers |  | 15d | 2019-09-25 | 2019-10-09 | A34792, A34802, A34812, 1F5-FNS-P06-630 | 78.25d | 0d |  | Fire Fighting Crew [150 h] | 14.15 | MEP | 3 | MB | 1633 | CON |
| A34842 |  | Instalaltion of Fire Extinguisher |  | 10d | 2019-10-09 | 2019-10-19 | A34792, A34832, A35172 FF, LOE-SUM3-120 FF | 133.25d | 133.75d |  | Fire Fighting Crew [100 h] | 9.43 | MEP | 3 | MB |  | CON |
| A35172 |  | Installation of Fire hose Cabinet |  | 5d | 2019-10-09 | 2019-10-14 | A34792, A34832 | 138.25d | 5d |  | Fire Fighting Crew [50 h] | 4.71 | MEP | 3 | MB |  |  |
|  | 2 | **NORTH PLATFORM - SIEMENS ROOM ZONE 01 AND 02** |  |  | 2019-02-09 | 2019-10-24 |  |  |  |  |  |  |  |  |  |  |  |
| LOE-SUM3-130 |  | North . P06 . Siemens Rm - MEP Works; 1st & 2nd Fix | level of effort | 113.25d | 2019-02-09 | 2019-05-25 | RM43 | 202.5d | 0d | Saudi |  |  | MEP |  |  |  |  |
| LOE-SUM3-140 |  | North . P06 . Siemens Rm - MEP Works; Final Fix | level of effort | 111.5d | 2019-03-16 | 2019-06-27 | LOE-SUM3-130, A39362 SS | 254.25d | 0d | Saudi |  |  | MEP |  |  |  |  |
| LOE-SUM3-150 |  | North . P06 - MEP Works; Final fix | level of effort | 121.75d | 2019-06-23 | 2019-10-15 | LOE-SUM3-140, A41522 | 62.25d | 0d | Saudi |  |  | MEP |  |  |  |  |
|  | 4 | **P06 - PLATFORM - SIEMENS ROOM ZONE 01** |  |  | 2019-02-12 | 2019-06-27 |  |  |  |  |  |  |  |  |  |  |  |
|  | 1.4.1.4.1.1.4.1.1 | **HVAC SYSTEM** |  |  | 2019-02-12 | 2019-06-18 |  |  |  |  |  |  |  |  |  |  |  |
|  | 1.4.1.4.1.1.4.1.1.1. | **1st Fix** |  |  | 2019-02-12 | 2019-02-28 |  |  |  |  |  |  |  |  |  |  |  |
| A36942 |  | Hanger and support Installation - Duct |  | 6d | 2019-02-12 | 2019-02-17 | RM48 | 85.75d | 0d |  | Mechanical Crew [60 h] | 5.66 | MEP | 1 | MB | 1546 | CON |
| A37012 |  | Hanger and support Installation - CHW |  | 6d | 2019-02-12 | 2019-02-17 | A36942 SS | 85.75d | 0d |  | Mechanical Crew [60 h] | 5.66 | MEP | 1 | MB |  |  |
| A36922 |  | Duct Installation |  | 12d | 2019-02-13 | 2019-02-25 | A36942 SS+2d | 274d | 0d |  | Duct Installation [174 Sqmt]; HVAC [520 h] | 49.04 | MEP | 1 | MB | 1549 | CON |
| A36932 |  | Duct Insulation |  | 8d | 2019-02-17 | 2019-02-24 | A36922 SS+3d | 298d | 104d |  | Duct Insulation [180 Sqmt]; HVAC [128 h] | 12.07 | MEP | 1 | MB | 1552 | CON |
| A37032 |  | Chilled Water Piping Installation |  | 12d | 2019-02-17 | 2019-02-28 | A37012 | 85.75d | 0d |  | Mechanical Crew [120 h] | 11.32 | MEP | 1 | MB |  |  |

| ID | WBS | Activity | Duration | Start | Finish | Predecessors | Total float | Free float | Resources | Cost | Discipline | AREA | LOCATION | MSP Activity ID | MEP-Phase |
| --- | --- | --- | --- | --- | --- | --- | --- | --- | --- | --- | --- | --- | --- | --- | --- |
|  | 1.4.1.4.1.1.4.1.1.-1 | **2nd Fix** |  | 2019-02-25 | 2019-03-19 |  |  |  |  |  |  |  |  |  |  |
| A37022 |  | Installation of Duct Accessories (VD, FD, MSD etc....) | 12d | 2019-02-25 | 2019-03-07 | A36922 | 285d | 91d | Mechanical Crew [120 h] | 11.32 | MEP | 1 | MB |  |  |
| A37122 |  | CRAC Units Installation | 15d | 2019-02-25 | 2019-03-11 | A36922 | 274d | 9d | Mechanical Crew [150 h] | 14.15 | MEP | 1 | MB |  |  |
| A37132 |  | FCU Installation | 15d | 2019-02-25 | 2019-03-11 | A36922 | 274d | 9d | Mechanical Crew [150 h] | 14.15 | MEP | 1 | MB |  |  |
| A37142 |  | VRF DX Units Installation | 12d | 2019-02-25 | 2019-03-07 | A36922 | 277d | 12d | Mechanical Crew [120 h] | 11.32 | MEP | 1 | MB |  |  |
| A37152 |  | Installation of Attenuators | 10d | 2019-02-25 | 2019-03-06 | A36922 | 279d | 14d | Mechanical Crew [100 h] | 9.43 | MEP | 1 | MB |  |  |
| A37162 |  | Installation of HVAC Fans | 10d | 2019-02-25 | 2019-03-06 | A36922 | 279d | 14d | Mechanical Crew [100 h] | 9.43 | MEP | 1 | MB |  |  |
| A37182 |  | Pressurization Unit | 8d | 2019-02-25 | 2019-03-04 | A36922 | 281d | 16d | Mechanical Crew [80 h] | 7.54 | MEP | 1 | MB |  |  |
| A37192 |  | Dosing pot | 5d | 2019-02-25 | 2019-03-02 | A36922 | 284d | 19d | Mechanical Crew [50 h] | 4.71 | MEP | 1 | MB |  |  |
| A37212 |  | Air Handling Units Installation | 12d | 2019-02-25 | 2019-03-07 | A36922 | 277d | 12d | Mechanical Crew [120 h] | 11.32 | MEP | 1 | MB |  |  |
| A37052 |  | Valves and Accessories | 10d | 2019-02-28 | 2019-03-10 | A37032 | 85.75d | 0d | Mechanical Crew [100 h] | 9.43 | MEP | 1 | MB |  |  |
| A37172 |  | Air-Cooled Chillers | 15d | 2019-02-28 | 2019-03-14 | A37032 | 270d | 5d | Mechanical Crew [150 h] | 14.15 | MEP | 1 | MB |  |  |
| A37222 |  | Chilled Water Pump Installation | 12d | 2019-02-28 | 2019-03-11 | A37032 | 273d | 8d | Mechanical Crew [120 h] | 11.32 | MEP | 1 | MB |  |  |
| A37062 |  | Chilled Water Pipe Insulation and Cladding | 10d | 2019-03-10 | 2019-03-19 | A37032, A37052 | 85.75d | 0d | Mechanical Crew [100 h] | 9.43 | MEP | 1 | MB |  |  |
|  | 1.4.1.4.1.1.4.1.1.-2 | **HVAC_Final Fix** |  | 2019-03-19 | 2019-06-18 |  |  |  |  |  |  |  |  |  |  |
| A37202 |  | Equuipment Connection | 8d | 2019-03-19 | 2019-03-26 | A37222, A37212, A37172, A37162, A37152, A37122, A37132, A37142, A37192, A37182, A37062 | 265d | 71d | Mechanical Crew [80 h] | 7.54 | MEP | 1 | MB |  |  |
| A37042 |  | Air Outlets (Grills, Diffusers, Registers etc...) | 15d | 2019-06-01 | 2019-06-18 | A37022, A36922, A36932, A37202, 1F5-FNS-P06-960 | 194d | 184.5d | Mechanical Crew [150 h] | 14.15 | MEP | 1 | MB |  |  |
|  | 1.4.1.4.1.1.4.1.2 | **PLUMBING SYSTEM** |  | 2019-02-12 | 2019-05-22 |  |  |  |  |  |  |  |  |  |  |
|  | 1.4.1.4.1.1.4.1.2.1. | **1st Fix** |  | 2019-02-12 | 2019-03-07 |  |  |  |  |  |  |  |  |  |  |
| A36802 |  | Hanger and support Installation | 10d | 2019-02-12 | 2019-02-20 | RM48 | 81.75d | 0d | Plumbing Crew [100 h] | 9.43 | MEP | 1 | MB | 1566 | CON |
| A36842 |  | Drainage and Vent Pipe & Fittings | 20d | 2019-02-17 | 2019-03-06 | A36802 SS+5d | 294d | 1d | Plumbing Crew [200 h] | 18.86 | MEP | 1 | MB | 1573 | CON |
| A36812 |  | Domestic Water Pipe & Fittings | 20d | 2019-02-17 | 2019-03-07 | A36802 SS+6d | 81.75d | 0d | Plumbing Crew [200 h] | 18.86 | MEP | 1 | MB | 1570 | CON |
|  | 1.4.1.4.1.1.4.1.2.-1 | **2nd Fix** |  | 2019-03-07 | 2019-03-23 |  |  |  |  |  |  |  |  |  |  |
| A36822 |  | Domestic Water Valves | 12d | 2019-03-07 | 2019-03-19 | A36812 | 81.75d | 0d | Plumbing Crew [120 h] | 11.32 | MEP | 1 | MB | 1571 | CON |
| A37082 |  | Sewege Pumps Installation | 5d | 2019-03-07 | 2019-03-12 | A36842, A36812 | 293d | 73.5d | Plumbing Crew [50 h] | 4.71 | MEP | 1 | MB |  |  |
| A36832 |  | Leak Test | 4d | 2019-03-19 | 2019-03-23 | A36822 | 81.75d | 62.5d | Plumbing Crew [40 h] | 3.77 | MEP | 1 | MB | 1572 | CON |

| ID | WBS | Activity | Duration | Start | Finish | Predecessors | Total float | Free float | Resources | Cost | Discipline | AREA | LOCATION | MSP Activity ID | MEP-Phase |
| --- | --- | --- | --- | --- | --- | --- | --- | --- | --- | --- | --- | --- | --- | --- | --- |
|  | 1.4.1.4.1.1.4.1.2.-2 | **PLM_Final Fix** |  | 2019-05-20 | 2019-05-22 |  |  |  |  |  |  |  |  |  |  |
| A37072 |  | Water Heaters | 2d | 2019-05-20 | 2019-05-22 | A36832, A36842, A36812, 1F5-FNS-P06-720 FF | 219.5d | 0d | Plumbing Crew [20 h] | 1.89 | MEP | 1 | MB |  |  |
| A37092 |  | Floor Drain | 2d | 2019-05-20 | 2019-05-22 | A37072 SS | 219.5d | 0d | Plumbing Crew [20 h] | 1.89 | MEP | 1 | MB |  |  |
| A37102 |  | Wash Basin / Water Closet | 2d | 2019-05-20 | 2019-05-22 | A37092 SS | 219.5d | 0d | Plumbing Crew [20 h] | 1.89 | MEP | 1 | MB |  |  |
| A37112 |  | Eye Wash | 2d | 2019-05-20 | 2019-05-22 | A37102 SS, A37082 | 219.5d | 197d | Plumbing Crew [20 h] | 1.89 | MEP | 1 | MB |  |  |
|  | 1.4.1.4.1.1.4.1.3 | **ELECTRICAL / CONTROLS** |  | 2019-02-12 | 2019-06-25 |  |  |  |  |  |  |  |  |  |  |
|  | 1.4.1.4.1.1.4.1.3.1. | **1st Fix** |  | 2019-02-12 | 2019-03-13 |  |  |  |  |  |  |  |  |  |  |
| A36902 |  | Installation of Conduits and Boxes | 12d | 2019-02-12 | 2019-02-23 | RM48 | 11.75d | 0d | Electrical Crew [120 h] | 11.32 | MEP | 1 | MB | 1592 | CON |
| A36912 |  | Installation of Cable Tray, Ladder and Trunk | 20d | 2019-02-23 | 2019-03-13 | A36902 | 69.25d | 0d | Electrical Crew [200 h] | 18.86 | MEP | 1 | MB | 1593 | CON |
|  | 1.4.1.4.1.1.4.1.3.-1 | **2nd Fix** |  | 2019-02-23 | 2019-05-25 |  |  |  |  |  |  |  |  |  |  |
| A36872 |  | Grounding and Bonding Installation | 20d | 2019-02-23 | 2019-03-13 | A36902 | 11.75d | 0d | Electrical Crew [200 h] | 18.86 | MEP | 1 | MB | 1596 | CON |
| A37232 |  | Wire Pulling | 20d | 2019-03-13 | 2019-04-01 | A36872 | 11.75d | 0d | Electrical Crew [200 h] | 18.86 | MEP | 1 | MB |  |  |
| A37292 |  | Installation of Bus Duct System | 20d | 2019-03-13 | 2019-04-01 | A36912 | 69.25d | 57.5d | Electrical Crew [200 h] | 18.86 | MEP | 1 | MB |  |  |
| A36852 |  | Power Cable Laying | 25d | 2019-04-01 | 2019-04-24 | A37232, A36872 | 11.75d | 0d | Electrical Crew [250 h] | 23.58 | MEP | 1 | MB | 1600 | CON |
| A36862 |  | Continuity Test - Power Cables | 6.25d | 2019-04-24 | 2019-04-30 | A36852 | 38d | 26.25d | Electrical Crew [62.5 h] | 5.89 | MEP | 1 | MB | 1601 | CON |
| A37242 |  | Installation of Central Battery Equipment | 6d | 2019-04-24 | 2019-04-30 | A36852, A37232 | 38.25d | 26.5d | Electrical Crew [60 h] | 5.66 | MEP | 1 | MB |  |  |
| A37252 |  | Installation of Disconnect Switch | 8d | 2019-04-24 | 2019-05-01 | A36852, A37232 | 36.25d | 24.5d | Electrical Crew [80 h] | 7.54 | MEP | 1 | MB |  |  |
| A37272 |  | Installation of Switch Boards (MDB, EMDB) | 15d | 2019-04-24 | 2019-05-08 | A36852, A37232 | 11.75d | 0d | Electrical Crew [150 h] | 14.15 | MEP | 1 | MB |  |  |
| A37282 |  | Installation of Panel Boards | 15d | 2019-04-24 | 2019-05-08 | A36852, A37232 | 11.75d | 0d | Electrical Crew [150 h] | 14.15 | MEP | 1 | MB |  |  |
| A37302 |  | Installation of MCC | 15d | 2019-04-24 | 2019-05-08 | A36852, A37232 | 11.75d | 0d | Electrical Crew [150 h] | 14.15 | MEP | 1 | MB |  |  |
| A37312 |  | Installation of Lighting Control System | 15d | 2019-04-24 | 2019-05-08 | A36852, A37232 | 11.75d | 0d | Electrical Crew [150 h] | 14.15 | MEP | 1 | MB |  |  |
| A37262 |  | Installation of Wiring Devices and Outlets | 17.5d | 2019-05-08 | 2019-05-25 | A37232, A37302, A37282, A37272, A37312 | 11.75d | 0d | Electrical Crew [175 h] | 16.5 | MEP | 1 | MB |  |  |
|  | 1.4.1.4.1.1.4.1.3.-2 | **Elec._Final Fix** |  | 2019-05-25 | 2019-06-25 |  |  |  |  |  |  |  |  |  |  |
| A36892 |  | Wiring devices Termination | 10d | 2019-05-25 | 2019-06-03 | A37242, A37252, A37292, A37312, A37262, A36862 | 11.75d | 0d | Electrical Crew [100 h] | 9.43 | MEP | 1 | MB | 1617 | CON |
| A37322 |  | Panel Board Termination | 10d | 2019-06-03 | 2019-06-16 | A37272, A37282, A37302, A37262, A36892 | 11.75d | 0d | Electrical Crew [100 h] | 9.43 | MEP | 1 | MB |  |  |
| A36882 |  | Lighting Fixtures Installation and Termination | 10d | 2019-06-16 | 2019-06-25 | A36852, A37232, A37322, A36892, 1F5-FNS-P06-960, LOE-SUM3-140 FF | 11.75d | 0d | Electrical Crew [100 h] | 9.43 | MEP | 1 | MB | 1616 | CON |

| ID | WBS | Activity | Duration | Start | Finish | Predecessors | Total float | Free float | Resources | Cost | MSP Activity ID | Discipline | MEP-Phase | AREA | LOCATION |
| --- | --- | --- | --- | --- | --- | --- | --- | --- | --- | --- | --- | --- | --- | --- | --- |
|  | 1.4.1.4.1.1.4.1.4 | **FIRE FIGHTING SYSTEM** |  | 2019-02-12 | 2019-06-27 |  |  |  |  |  |  |  |  |  |  |
|  | 1.4.1.4.1.1.4.1.4.1. | **1st Fix** |  | 2019-02-12 | 2019-03-25 |  |  |  |  |  |  |  |  |  |  |
| A36982 |  | Fire Fighting Hangers & Supports | 15d | 2019-02-12 | 2019-02-25 | RM48 | 48.75d | 0d | Fire Fighting Crew [150 h] | 14.15 | 1622 | MEP | CON | 1 | MB |
| A36952 |  | Pipe Installation | 30d | 2019-02-26 | 2019-03-25 | A36982 | 48.75d | 0d | FIRE FIGHTING [241 h]; FF pipe [137 Limt] | 22.73 | 1625 | MEP | CON | 1 | MB |
|  | 1.4.1.4.1.1.4.1.4.-1 | **2nd Fix** |  | 2019-03-26 | 2019-04-22 |  |  |  |  |  |  |  |  |  |  |
| A36962 |  | Valve and Accessories Installation | 20d | 2019-03-26 | 2019-04-13 | A36952, A36982 | 48.75d | 0d | Fire Fighting Crew [200 h] | 18.86 | 1627 | MEP | CON | 1 | MB |
| A36972 |  | Leak Test | 10d | 2019-04-14 | 2019-04-22 | A36962 | 48.75d | 34.5d | Fire Fighting Crew [100 h] | 9.43 | 1631 | MEP | CON | 1 | MB |
|  | 1.4.1.4.1.1.4.1.4.-2 | **FF_Final Fix** |  | 2019-06-01 | 2019-06-27 |  |  |  |  |  |  |  |  |  |  |
| A36992 |  | Installation of Sprinklers | 15d | 2019-06-01 | 2019-06-18 | A36952, A36962, A36972, 1F5-FNS-P06-960 | 194d | 0d | Fire Fighting Crew [150 h] | 14.15 | 1633 | MEP | CON | 1 | MB |
| A37002 |  | Instalaltion of Fire Extinguisher | 10d | 2019-06-18 | 2019-06-27 | A36952, A36992, A37332 FF, LOE-SUM3-140 FF | 249d | 249.5d | Fire Fighting Crew [100 h] | 9.43 |  | MEP | CON | 1 | MB |
| A37332 |  | Installation of Fire hose Cabinet | 5d | 2019-06-18 | 2019-06-23 | A36952, A36992 | 254d | 5d | Fire Fighting Crew [50 h] | 4.71 |  | MEP |  | 1 | MB |
|  | 5 | **P06 - PLATFORM - SIEMENS ROOM ZONE 02** |  | 2019-02-09 | 2019-06-18 |  |  |  |  |  |  |  |  |  |  |
|  | 1.4.1.4.1.1.4.1.1 | **HVAC SYSTEM** |  | 2019-02-09 | 2019-06-09 |  |  |  |  |  |  |  |  |  |  |
|  | 1.4.1.4.1.1.4.1.1.1. | **1st Fix** |  | 2019-02-09 | 2019-02-25 |  |  |  |  |  |  |  |  |  |  |
| A39102 |  | Hanger and support Installation - Duct | 6d | 2019-02-09 | 2019-02-13 | RM43 | 89.5d | 0d | Mechanical Crew [60 h] | 5.66 | 1546 | MEP | CON | 2 | MB |
| A39172 |  | Hanger and support Installation - CHW | 6d | 2019-02-09 | 2019-02-13 | A39102 SS | 89.5d | 0d | Mechanical Crew [60 h] | 5.66 |  | MEP |  | 2 | MB |
| A39082 |  | Duct Installation | 12d | 2019-02-10 | 2019-02-21 | A39102 SS+2d | 277.75d | 0d | Duct Installation [174 Sqmt]; HVAC [520 h] | 49.04 | 1549 | MEP | CON | 2 | MB |
| A39092 |  | Duct Insulation | 8d | 2019-02-13 | 2019-02-20 | A39082 SS+3d | 301.75d | 97.25d | Duct Insulation [180 Sqmt]; HVAC [128 h] | 12.07 | 1552 | MEP | CON | 2 | MB |
| A39192 |  | Chilled Water Piping Installation | 12d | 2019-02-13 | 2019-02-25 | A39172 | 89.5d | 0d | Mechanical Crew [120 h] | 11.32 |  | MEP |  | 2 | MB |
|  | 1.4.1.4.1.1.4.1.1.-1 | **2nd Fix** |  | 2019-02-21 | 2019-03-16 |  |  |  |  |  |  |  |  |  |  |
| A39182 |  | Installation of Duct Accessories (VD, FD, MSD etc....) | 12d | 2019-02-21 | 2019-03-04 | A39082 | 288.75d | 84.25d | Mechanical Crew [120 h] | 11.32 |  | MEP |  | 2 | MB |
| A39282 |  | CRAC Units Installation | 15d | 2019-02-21 | 2019-03-07 | A39082 | 277.75d | 9d | Mechanical Crew [150 h] | 14.15 |  | MEP |  | 2 | MB |
| A39292 |  | FCU Installation | 15d | 2019-02-21 | 2019-03-07 | A39082 | 277.75d | 9d | Mechanical Crew [150 h] | 14.15 |  | MEP |  | 2 | MB |
| A39302 |  | VRF DX Units Installation | 12d | 2019-02-21 | 2019-03-04 | A39082 | 280.75d | 12d | Mechanical Crew [120 h] | 11.32 |  | MEP |  | 2 | MB |
| A39312 |  | Installation of Attenuators | 10d | 2019-02-21 | 2019-03-03 | A39082 | 282.75d | 14d | Mechanical Crew [100 h] | 9.43 |  | MEP |  | 2 | MB |
| A39322 |  | Installation of HVAC Fans | 10d | 2019-02-21 | 2019-03-03 | A39082 | 282.75d | 14d | Mechanical Crew [100 h] | 9.43 |  | MEP |  | 2 | MB |
| A39342 |  | Pressurization Unit | 8d | 2019-02-21 | 2019-02-28 | A39082 | 284.75d | 16d | Mechanical Crew [80 h] | 7.54 |  | MEP |  | 2 | MB |
| A39352 |  | Dosing pot | 5d | 2019-02-21 | 2019-02-26 | A39082 | 287.75d | 19d | Mechanical Crew [50 h] | 4.71 |  | MEP |  | 2 | MB |
| A39372 |  | Air Handling Units Installation | 12d | 2019-02-21 | 2019-03-04 | A39082 | 280.75d | 12d | Mechanical Crew [120 h] | 11.32 |  | MEP |  | 2 | MB |
| A39212 |  | Valves and Accessories | 10d | 2019-02-25 | 2019-03-06 | A39192 | 89.5d | 0d | Mechanical Crew [100 h] | 9.43 |  | MEP |  | 2 | MB |
| A39332 |  | Air-Cooled Chillers | 15d | 2019-02-25 | 2019-03-11 | A39192 | 273.75d | 5d | Mechanical Crew [150 h] | 14.15 |  | MEP |  | 2 | MB |
| A39382 |  | Chilled Water Pump Installation | 12d | 2019-02-25 | 2019-03-07 | A39192 | 276.75d | 8d | Mechanical Crew [120 h] | 11.32 |  | MEP |  | 2 | MB |
| A39222 |  | Chilled Water Pipe Insulation and Cladding | 10d | 2019-03-06 | 2019-03-16 | A39192, A39212 | 89.5d | 0d | Mechanical Crew [100 h] | 9.43 |  | MEP |  | 2 | MB |

| ID | WBS | Activity | Duration | Start | Finish | Predecessors | Total float | Free float | Resources | Cost | Discipline | AREA | LOCATION | MSP Activity ID | MEP-Phase |
| --- | --- | --- | --- | --- | --- | --- | --- | --- | --- | --- | --- | --- | --- | --- | --- |
|  | 1.4.1.4.1.1.4.1.1.-2 | **HVAC_Final Fix** |  | 2019-03-16 | 2019-06-09 |  |  |  |  |  |  |  |  |  |  |
| A39362 |  | Equuipment Connection | 8d | 2019-03-16 | 2019-03-23 | A39382, A39372, A39332, A39322, A39312, A39282, A39292, A39302, A39352, A39342, A39222 | 268.75d | 64.25d | Mechanical Crew [80 h] | 7.54 | MEP | 2 | MB |  |  |
| A39202 |  | Air Outlets (Grills, Diffusers, Registers etc...) | 15d | 2019-05-22 | 2019-06-09 | A39182, A39082, A39092, A39362, 1F5-FNS-P06-720 | 204.5d | 195d | Mechanical Crew [150 h] | 14.15 | MEP | 2 | MB |  |  |
|  | 1.4.1.4.1.1.4.1.2 | **PLUMBING SYSTEM** |  | 2019-02-09 | 2019-03-21 |  |  |  |  |  |  |  |  |  |  |
|  | 1.4.1.4.1.1.4.1.2.1. | **1st Fix** |  | 2019-02-09 | 2019-03-04 |  |  |  |  |  |  |  |  |  |  |
| A38962 |  | Hanger and support Installation | 10d | 2019-02-09 | 2019-02-17 | RM43 | 85.5d | 0d | Plumbing Crew [100 h] | 9.43 | MEP | 2 | MB | 1566 | CON |
| A39002 |  | Drainage and Vent Pipe & Fittings | 20d | 2019-02-13 | 2019-03-03 | A38962 SS+5d | 297.75d | 1d | Plumbing Crew [200 h] | 18.86 | MEP | 2 | MB | 1573 | CON |
| A38972 |  | Domestic Water Pipe & Fittings | 20d | 2019-02-13 | 2019-03-04 | A38962 SS+6d | 85.5d | 0d | Plumbing Crew [200 h] | 18.86 | MEP | 2 | MB | 1570 | CON |
|  | 1.4.1.4.1.1.4.1.2.-1 | **2nd Fix** |  | 2019-03-04 | 2019-03-19 |  |  |  |  |  |  |  |  |  |  |
| A38982 |  | Domestic Water Valves | 12d | 2019-03-04 | 2019-03-16 | A38972 | 85.5d | 0d | Plumbing Crew [120 h] | 11.32 | MEP | 2 | MB | 1571 | CON |
| A39242 |  | Sewege Pumps Installation | 5d | 2019-03-04 | 2019-03-09 | A39002, A38972 | 296.75d | 11d | Plumbing Crew [50 h] | 4.71 | MEP | 2 | MB |  |  |
| A38992 |  | Leak Test | 4d | 2019-03-16 | 2019-03-19 | A38982 | 85.5d | 0d | Plumbing Crew [40 h] | 3.77 | MEP | 2 | MB | 1572 | CON |
|  | 1.4.1.4.1.1.4.1.2.-2 | **PLM_Final Fix** |  | 2019-03-19 | 2019-03-21 |  |  |  |  |  |  |  |  |  |  |
| A39232 |  | Water Heaters | 2d | 2019-03-19 | 2019-03-21 | A38992, A39002, A38972 | 285.75d | 0d | Plumbing Crew [20 h] | 1.89 | MEP | 2 | MB |  |  |
| A39252 |  | Floor Drain | 2d | 2019-03-19 | 2019-03-21 | A39232 SS | 285.75d | 0d | Plumbing Crew [20 h] | 1.89 | MEP | 2 | MB |  |  |
| A39262 |  | Wash Basin / Water Closet | 2d | 2019-03-19 | 2019-03-21 | A39252 SS | 285.75d | 0d | Plumbing Crew [20 h] | 1.89 | MEP | 2 | MB |  |  |
| A39272 |  | Eye Wash | 2d | 2019-03-19 | 2019-03-21 | A39262 SS, A39242 | 285.75d | 263.25d | Plumbing Crew [20 h] | 1.89 | MEP | 2 | MB |  |  |
|  | 1.4.1.4.1.1.4.1.3 | **ELECTRICAL / CONTROLS** |  | 2019-02-09 | 2019-06-01 |  |  |  |  |  |  |  |  |  |  |
|  | 1.4.1.4.1.1.4.1.3.1. | **1st Fix** |  | 2019-02-09 | 2019-03-10 |  |  |  |  |  |  |  |  |  |  |
| A39062 |  | Installation of Conduits and Boxes | 12d | 2019-02-09 | 2019-02-19 | RM43 | 23.5d | 0d | Electrical Crew [120 h] | 11.32 | MEP | 2 | MB | 1592 | CON |
| A39072 |  | Installation of Cable Tray, Ladder and Trunk | 20d | 2019-02-19 | 2019-03-10 | A39062 | 87d | 0d | Electrical Crew [200 h] | 18.86 | MEP | 2 | MB | 1593 | CON |
|  | 1.4.1.4.1.1.4.1.3.-1 | **2nd Fix** |  | 2019-02-19 | 2019-05-16 |  |  |  |  |  |  |  |  |  |  |
| A39032 |  | Grounding and Bonding Installation | 20d | 2019-02-19 | 2019-03-10 | A39062 | 23.5d | 0d | Electrical Crew [200 h] | 18.86 | MEP | 2 | MB | 1596 | CON |
| A39392 |  | Wire Pulling | 20d | 2019-03-10 | 2019-03-28 | A39032 | 23.5d | 0d | Electrical Crew [200 h] | 18.86 | MEP | 2 | MB |  |  |
| A39452 |  | Installation of Bus Duct System | 20d | 2019-03-10 | 2019-03-28 | A39072 | 87d | 52d | Electrical Crew [200 h] | 18.86 | MEP | 2 | MB |  |  |
| A39012 |  | Power Cable Laying | 25d | 2019-03-28 | 2019-04-21 | A39392, A39032 | 23.5d | 0d | Electrical Crew [250 h] | 23.58 | MEP | 2 | MB | 1600 | CON |
| A39022 |  | Continuity Test - Power Cables | 4d | 2019-04-21 | 2019-04-24 | A39012 | 58d | 23d | Electrical Crew [40 h] | 3.77 | MEP | 2 | MB | 1601 | CON |
| A39402 |  | Installation of Central Battery Equipment | 6d | 2019-04-21 | 2019-04-27 | A39012, A39392 | 56d | 21d | Electrical Crew [60 h] | 5.66 | MEP | 2 | MB |  |  |
| A39412 |  | Installation of Disconnect Switch | 8d | 2019-04-21 | 2019-04-28 | A39012, A39392 | 54d | 19d | Electrical Crew [80 h] | 7.54 | MEP | 2 | MB |  |  |
| A39432 |  | Installation of Switch Boards (MDB, EMDB) | 15d | 2019-04-21 | 2019-05-05 | A39012, A39392 | 23.5d | 0d | Electrical Crew [150 h] | 14.15 | MEP | 2 | MB |  |  |
| A39442 |  | Installation of Panel Boards | 15d | 2019-04-21 | 2019-05-05 | A39012, A39392 | 23.5d | 0d | Electrical Crew [150 h] | 14.15 | MEP | 2 | MB |  |  |
| A39462 |  | Installation of MCC | 15d | 2019-04-21 | 2019-05-05 | A39012, A39392 | 23.5d | 0d | Electrical Crew [150 h] | 14.15 | MEP | 2 | MB |  |  |
| A39472 |  | Installation of Lighting Control System | 12d | 2019-04-21 | 2019-05-02 | A39012, A39392 | 26.5d | 3d | Electrical Crew [120 h] | 11.32 | MEP | 2 | MB |  |  |
| A39422 |  | Installation of Wiring Devices and Outlets | 12d | 2019-05-05 | 2019-05-16 | A39392, A39462, A39442, A39432, A39472 | 23.5d | 0d | Electrical Crew [120 h] | 11.32 | MEP | 2 | MB |  |  |

| ID | WBS | Activity | Duration | Start | Finish | Predecessors | Total float | Free float | Resources | Cost | Discipline | AREA | LOCATION | MSP Activity ID | MEP-Phase |
| --- | --- | --- | --- | --- | --- | --- | --- | --- | --- | --- | --- | --- | --- | --- | --- |
|  | 1.4.1.4.1.1.4.1.3.-2 | **Elec._Final Fix** |  | 2019-05-05 | 2019-06-01 |  |  |  |  |  |  |  |  |  |  |
| A39482 |  | Panel Board Termination | 8d | 2019-05-05 | 2019-05-12 | A39432, A39442, A39462 | 45d | 10.25d | Electrical Crew [80 h] | 7.54 | MEP | 2 | MB |  |  |
| A39052 |  | Wiring devices Termination | 6d | 2019-05-16 | 2019-05-21 | A39402, A39412, A39452, A39472, A39422, A39022 | 35d | 0.25d | Electrical Crew [60 h] | 5.66 | MEP | 2 | MB | 1617 | CON |
| A39042 |  | Lighting Fixtures Installation and Termination | 10d | 2019-05-22 | 2019-06-01 | A39012, A39392, A39482, A39052, 1F5-FNS-P06-720 | 34.75d | 23d | Electrical Crew [100 h] | 9.43 | MEP | 2 | MB | 1616 | CON |
|  | 1.4.1.4.1.1.4.1.4 | **FIRE FIGHTING SYSTEM** |  | 2019-02-09 | 2019-06-18 |  |  |  |  |  |  |  |  |  |  |
|  | 1.4.1.4.1.1.4.1.4.1. | **1st Fix** |  | 2019-02-09 | 2019-03-21 |  |  |  |  |  |  |  |  |  |  |
| A39142 |  | Fire Fighting Hangers & Supports | 15d | 2019-02-09 | 2019-02-21 | RM43 | 52.5d | 0d | Fire Fighting Crew [150 h] | 14.15 | MEP | 2 | MB | 1622 | CON |
| A39112 |  | Pipe Installation | 30d | 2019-02-23 | 2019-03-21 | A39142 | 52.5d | 0d | FF pipe [137 Limt]; FIRE FIGHTING [241 h] | 22.73 | MEP | 2 | MB | 1625 | CON |
|  | 1.4.1.4.1.1.4.1.4.-1 | **2nd Fix** |  | 2019-03-23 | 2019-04-18 |  |  |  |  |  |  |  |  |  |  |
| A39122 |  | Valve and Accessories Installation | 20d | 2019-03-23 | 2019-04-09 | A39112, A39142 | 52.5d | 0d | Fire Fighting Crew [200 h] | 18.86 | MEP | 2 | MB | 1627 | CON |
| A39132 |  | Leak Test | 10d | 2019-04-10 | 2019-04-18 | A39122 | 52.5d | 29d | Fire Fighting Crew [100 h] | 9.43 | MEP | 2 | MB | 1631 | CON |
|  | 1.4.1.4.1.1.4.1.4.-2 | **FF_Final Fix** |  | 2019-05-22 | 2019-06-18 |  |  |  |  |  |  |  |  |  |  |
| A39152 |  | Installation of Sprinklers | 15d | 2019-05-22 | 2019-06-09 | A39112, A39122, A39132, 1F5-FNS-P06-720 | 204.5d | 0d | Fire Fighting Crew [150 h] | 14.15 | MEP | 2 | MB | 1633 | CON |
| A39162 |  | Instalaltion of Fire Extinguisher | 10d | 2019-06-09 | 2019-06-18 | A39112, A39152, A39492 FF | 259.5d | 260d | Fire Fighting Crew [100 h] | 9.43 | MEP | 2 | MB |  | CON |
| A39492 |  | Installation of Fire hose Cabinet | 5d | 2019-06-09 | 2019-06-13 | A39112, A39152 | 264.5d | 5d | Fire Fighting Crew [50 h] | 4.71 | MEP | 2 | MB |  |  |
|  | 1 | **P06 - PLATFORM OUTSIDE SIEMENS ROOM ZONE 1 & 2** |  | 2019-05-08 | 2019-10-24 |  |  |  |  |  |  |  |  |  |  |
|  | 1.4.1.4.1.1.4.1.1 | **HVAC SYSTEM** |  | 2019-05-08 | 2019-09-10 |  |  |  |  |  |  |  |  |  |  |
|  | 1.4.1.4.1.1.4.1.1.1. | **1st Fix** |  | 2019-05-08 | 2019-05-25 |  |  |  |  |  |  |  |  |  |  |
| A41262 |  | Hanger and support Installation - Duct | 6d | 2019-05-08 | 2019-05-13 | RM40, RM45 | 165.75d | 0d | Mechanical Crew [60 h] | 5.66 | MEP | 2 | MB | 1546 | CON |
| A41332 |  | Hanger and support Installation - CHW | 6d | 2019-05-08 | 2019-05-13 | A41262 SS | 165.75d | 0d | Mechanical Crew [60 h] | 5.66 | MEP | 2 | MB |  |  |
| A41242 |  | Duct Installation | 12d | 2019-05-09 | 2019-05-21 | A41262 SS+2d | 182.75d | 0d | Duct Installation [174 Sqmt]; HVAC [520 h] | 49.04 | MEP | 2 | MB | 1549 | CON |
| A41252 |  | Duct Insulation | 8d | 2019-05-13 | 2019-05-20 | A41242 SS+3d | 206.75d | 98.5d | Duct Insulation [180 Sqmt]; HVAC [128 h] | 12.07 | MEP | 2 | MB | 1552 | CON |
| A41352 |  | Chilled Water Piping Installation | 12d | 2019-05-13 | 2019-05-25 | A41332 | 165.75d | 0d | Mechanical Crew [120 h] | 11.32 | MEP | 2 | MB |  |  |
|  | 1.4.1.4.1.1.4.1.1.-1 | **2nd Fix** |  | 2019-05-21 | 2019-06-16 |  |  |  |  |  |  |  |  |  |  |
| A41342 |  | Installation of Duct Accessories (VD, FD, MSD etc....) | 12d | 2019-05-21 | 2019-06-01 | A41242 | 193.75d | 85.5d | Mechanical Crew [120 h] | 11.32 | MEP | 2 | MB |  |  |
| A41442 |  | CRAC Units Installation | 15d | 2019-05-21 | 2019-06-08 | A41242 | 182.75d | 9d | Mechanical Crew [150 h] | 14.15 | MEP | 2 | MB |  |  |
| A41452 |  | FCU Installation | 15d | 2019-05-21 | 2019-06-08 | A41242 | 182.75d | 9d | Mechanical Crew [150 h] | 14.15 | MEP | 2 | MB |  |  |
| A41462 |  | VRF DX Units Installation | 12d | 2019-05-21 | 2019-06-01 | A41242 | 185.75d | 12d | Mechanical Crew [120 h] | 11.32 | MEP | 2 | MB |  |  |
| A41472 |  | Installation of Attenuators | 10d | 2019-05-21 | 2019-05-30 | A41242 | 187.75d | 14d | Mechanical Crew [100 h] | 9.43 | MEP | 2 | MB |  |  |
| A41482 |  | Installation of HVAC Fans | 10d | 2019-05-21 | 2019-05-30 | A41242 | 187.75d | 14d | Mechanical Crew [100 h] | 9.43 | MEP | 2 | MB |  |  |
| A41502 |  | Pressurization Unit | 8d | 2019-05-21 | 2019-05-28 | A41242 | 189.75d | 16d | Mechanical Crew [80 h] | 7.54 | MEP | 2 | MB |  |  |
| A41512 |  | Dosing pot | 5d | 2019-05-21 | 2019-05-26 | A41242 | 192.75d | 19d | Mechanical Crew [50 h] | 4.71 | MEP | 2 | MB |  |  |
| A41532 |  | Air Handling Units Installation | 12d | 2019-05-21 | 2019-06-01 | A41242 | 185.75d | 12d | Mechanical Crew [120 h] | 11.32 | MEP | 2 | MB |  |  |
| A41372 |  | Valves and Accessories | 10d | 2019-05-25 | 2019-06-03 | A41352 | 165.75d | 0d | Mechanical Crew [100 h] | 9.43 | MEP | 2 | MB |  |  |
| A41492 |  | Air-Cooled Chillers | 15d | 2019-05-25 | 2019-06-11 | A41352 | 178.75d | 5d | Mechanical Crew [150 h] | 14.15 | MEP | 2 | MB |  |  |
| A41542 |  | Chilled Water Pump Installation | 12d | 2019-05-25 | 2019-06-08 | A41352 | 181.75d | 8d | Mechanical Crew [120 h] | 11.32 | MEP | 2 | MB |  |  |
| A41382 |  | Chilled Water Pipe Insulation and Cladding | 10d | 2019-06-03 | 2019-06-16 | A41352, A41372 | 165.75d | 0d | Mechanical Crew [100 h] | 9.43 | MEP | 2 | MB |  |  |

| ID | WBS | Activity | Duration | Start | Finish | Predecessors | Total float | Free float | Resources | Cost | Discipline | AREA | LOCATION | MSP Activity ID | MEP-Phase |
| --- | --- | --- | --- | --- | --- | --- | --- | --- | --- | --- | --- | --- | --- | --- | --- |
|  | 1.4.1.4.1.1.4.1.1.-2 | **HVAC_Final Fix** |  | 2019-06-16 | 2019-09-10 |  |  |  |  |  |  |  |  |  |  |
| A41522 |  | Equuipment Connection | 8d | 2019-06-16 | 2019-06-23 | A41542, A41532, A41492, A41482, A41472, A41442, A41452, A41462, A41512, A41502, A41382 | 173.75d | 65.5d | Mechanical Crew [80 h] | 7.54 | MEP | 2 | MB |  |  |
| A41362 |  | Air Outlets (Grills, Diffusers, Registers etc...) | 15d | 2019-08-27 | 2019-09-10 | A41342, A41242, A41252, A41522, 1F5-FNS-P06-850 | 108.25d | 98.75d | Mechanical Crew [150 h] | 14.15 | MEP | 2 | MB |  |  |
|  | 1.4.1.4.1.1.4.1.2 | **PLUMBING SYSTEM** |  | 2019-05-08 | 2019-10-10 |  |  |  |  |  |  |  |  |  |  |
|  | 1.4.1.4.1.1.4.1.2.1. | **1st Fix** |  | 2019-05-08 | 2019-06-01 |  |  |  |  |  |  |  |  |  |  |
| A41122 |  | Hanger and support Installation | 10d | 2019-05-08 | 2019-05-16 | RM40, RM45 | 161.75d | 0d | Plumbing Crew [100 h] | 9.43 | MEP | 2 | MB | 1566 | CON |
| A41162 |  | Drainage and Vent Pipe & Fittings | 20d | 2019-05-13 | 2019-05-30 | A41122 SS+5d | 267.75d | 1d | Plumbing Crew [200 h] | 18.86 | MEP | 2 | MB | 1573 | CON |
| A41132 |  | Domestic Water Pipe & Fittings | 20d | 2019-05-13 | 2019-06-01 | A41122 SS+6d | 161.75d | 0d | Plumbing Crew [200 h] | 18.86 | MEP | 2 | MB | 1570 | CON |
|  | 1.4.1.4.1.1.4.1.2.-1 | **2nd Fix** |  | 2019-06-01 | 2019-06-19 |  |  |  |  |  |  |  |  |  |  |
| A41142 |  | Domestic Water Valves | 12d | 2019-06-01 | 2019-06-16 | A41132 | 161.75d | 0d | Plumbing Crew [120 h] | 11.32 | MEP | 2 | MB | 1571 | CON |
| A41402 |  | Sewege Pumps Installation | 5d | 2019-06-01 | 2019-06-09 | A41162, A41132 | 266.75d | 125.5d | Plumbing Crew [50 h] | 4.71 | MEP | 2 | MB |  |  |
| A41152 |  | Leak Test | 4d | 2019-06-16 | 2019-06-19 | A41142 | 161.75d | 62d | Plumbing Crew [40 h] | 3.77 | MEP | 2 | MB | 1572 | CON |
|  | 1.4.1.4.1.1.4.1.2.-2 | **PLM_Final Fix** |  | 2019-10-09 | 2019-10-10 |  |  |  |  |  |  |  |  |  |  |
| A41392 |  | Water Heaters | 2d | 2019-10-09 | 2019-10-10 | A41152, A41162, A41132, 1F5-FNS-P06-860 | 141.25d | 0d | Plumbing Crew [20 h] | 1.89 | MEP | 2 | MB |  |  |
| A41412 |  | Floor Drain | 2d | 2019-10-09 | 2019-10-10 | A41392 SS | 141.25d | 0d | Plumbing Crew [20 h] | 1.89 | MEP | 2 | MB |  |  |
| A41422 |  | Wash Basin / Water Closet | 2d | 2019-10-09 | 2019-10-10 | A41412 SS | 141.25d | 0d | Plumbing Crew [20 h] | 1.89 | MEP | 2 | MB |  |  |
| A41432 |  | Eye Wash | 2d | 2019-10-09 | 2019-10-10 | A41422 SS, A41402 | 141.25d | 141.75d | Plumbing Crew [20 h] | 1.89 | MEP | 2 | MB |  |  |
|  | 1.4.1.4.1.1.4.1.3 | **ELECTRICAL / CONTROLS** |  | 2019-05-08 | 2019-10-24 |  |  |  |  |  |  |  |  |  |  |
|  | 1.4.1.4.1.1.4.1.3.1. | **1st Fix** |  | 2019-05-08 | 2019-06-10 |  |  |  |  |  |  |  |  |  |  |
| A41222 |  | Installation of Conduits and Boxes | 12d | 2019-05-08 | 2019-05-19 | RM40, RM45 | 99.75d | 0d | Electrical Crew [120 h] | 11.32 | MEP | 2 | MB | 1592 | CON |
| A41232 |  | Installation of Cable Tray, Ladder and Trunk | 20d | 2019-05-19 | 2019-06-10 | A41222 | 166.75d | 0d | Electrical Crew [200 h] | 18.86 | MEP | 2 | MB | 1593 | CON |
|  | 1.4.1.4.1.1.4.1.3.-1 | **2nd Fix** |  | 2019-05-19 | 2019-08-20 |  |  |  |  |  |  |  |  |  |  |
| A41192 |  | Grounding and Bonding Installation | 20d | 2019-05-19 | 2019-06-10 | A41222 | 99.75d | 0d | Electrical Crew [200 h] | 18.86 | MEP | 2 | MB | 1596 | CON |
| A41552 |  | Wire Pulling | 20d | 2019-06-10 | 2019-06-29 | A41192 | 99.75d | 0d | Electrical Crew [200 h] | 18.86 | MEP | 2 | MB |  |  |
| A41612 |  | Installation of Bus Duct System | 20d | 2019-06-10 | 2019-06-29 | A41232 | 166.75d | 104.5d | Electrical Crew [200 h] | 18.86 | MEP | 2 | MB |  |  |
| A41172 |  | Power Cable Laying | 25d | 2019-06-29 | 2019-07-22 | A41552, A41192 | 99.75d | 0d | Electrical Crew [250 h] | 23.58 | MEP | 2 | MB | 1600 | CON |
| A41182 |  | Continuity Test - Power Cables | 4d | 2019-07-22 | 2019-07-25 | A41172 | 137.75d | 75.5d | Electrical Crew [40 h] | 3.77 | MEP | 2 | MB | 1601 | CON |
| A41562 |  | Installation of Central Battery Equipment | 6d | 2019-07-22 | 2019-07-28 | A41172, A41552 | 135.75d | 73.5d | Electrical Crew [60 h] | 5.66 | MEP | 2 | MB |  |  |
| A41572 |  | Installation of Disconnect Switch | 8d | 2019-07-22 | 2019-07-29 | A41172, A41552 | 133.75d | 71.5d | Electrical Crew [80 h] | 7.54 | MEP | 2 | MB |  |  |
| A41592 |  | Installation of Switch Boards (MDB, EMDB) | 15d | 2019-07-22 | 2019-08-05 | A41172, A41552 | 99.75d | 0d | Electrical Crew [150 h] | 14.15 | MEP | 2 | MB |  |  |
| A41602 |  | Installation of Panel Boards | 15d | 2019-07-22 | 2019-08-05 | A41172, A41552 | 99.75d | 0d | Electrical Crew [150 h] | 14.15 | MEP | 2 | MB |  |  |
| A41622 |  | Installation of MCC | 15d | 2019-07-22 | 2019-08-05 | A41172, A41552 | 99.75d | 0d | Electrical Crew [150 h] | 14.15 | MEP | 2 | MB |  |  |
| A41632 |  | Installation of Lighting Control System | 12d | 2019-07-22 | 2019-08-03 | A41172, A41552 | 102.75d | 3d | Electrical Crew [120 h] | 11.32 | MEP | 2 | MB |  |  |
| A41582 |  | Installation of Wiring Devices and Outlets | 12d | 2019-08-05 | 2019-08-20 | A41552, A41622, A41602, A41592, A41632 | 99.75d | 0d | Electrical Crew [120 h] | 11.32 | MEP | 2 | MB |  |  |

| ID | WBS | Activity | Type | Duration | Start | Finish | Predecessors | Total float | Free float | Calendar | Resources | Cost | Discipline | AREA | LOCATION | MSP Activity ID | MEP-Phase |
| --- | --- | --- | --- | --- | --- | --- | --- | --- | --- | --- | --- | --- | --- | --- | --- | --- | --- |
|  | 1.4.1.4.1.1.4.1.3.-2 | **Elec._Final Fix** |  |  | 2019-08-05 | 2019-10-24 |  |  |  |  |  |  |  |  |  |  |  |
| A41642 |  | Panel Board Termination |  | 8d | 2019-08-05 | 2019-08-15 | A41592, A41602, A41622 | 124.75d | 62.5d |  | Electrical Crew [80 h] | 7.54 | MEP | 2 | MB |  |  |
| A41212 |  | Wiring devices Termination |  | 6d | 2019-10-09 | 2019-10-15 | A41562, A41572, A41612, A41632, A41582, A41182, 1F5-FNS-P06-860 | 62.25d | 0d |  | Electrical Crew [60 h] | 5.66 | MEP | 2 | MB | 1617 | CON |
| A41202 |  | Lighting Fixtures Installation and Termination |  | 10d | 2019-10-15 | 2019-10-24 | A41172, A41552, A41642, A41212, 1F5-FNS-P06-850, LOE-SUM3-150 | 62.25d | 47.75d |  | Electrical Crew [100 h] | 9.43 | MEP | 2 | MB | 1616 | CON |
|  | 1.4.1.4.1.1.4.1.4 | **FIRE FIGHTING SYSTEM** |  |  | 2019-05-08 | 2019-09-19 |  |  |  |  |  |  |  |  |  |  |  |
|  | 1.4.1.4.1.1.4.1.4.1. | **1st Fix** |  |  | 2019-05-08 | 2019-06-22 |  |  |  |  |  |  |  |  |  |  |  |
| A41302 |  | Fire Fighting Hangers & Supports |  | 15d | 2019-05-08 | 2019-05-21 | RM40, RM45 | 128.75d | 0d |  | Fire Fighting Crew [150 h] | 14.15 | MEP | 2 | MB | 1622 | CON |
| A41272 |  | Pipe Installation |  | 30d | 2019-05-22 | 2019-06-22 | A41302 | 128.75d | 0d |  | FIRE FIGHTING [241 h]; FF pipe [137 Limt] | 22.73 | MEP | 2 | MB | 1625 | CON |
|  | 1.4.1.4.1.1.4.1.4.-1 | **2nd Fix** |  |  | 2019-06-23 | 2019-07-20 |  |  |  |  |  |  |  |  |  |  |  |
| A41282 |  | Valve and Accessories Installation |  | 20d | 2019-06-23 | 2019-07-10 | A41272, A41302 | 128.75d | 0d |  | Fire Fighting Crew [200 h] | 18.86 | MEP | 2 | MB | 1627 | CON |
| A41292 |  | Leak Test |  | 10d | 2019-07-11 | 2019-07-20 | A41282 | 128.75d | 29d |  | Fire Fighting Crew [100 h] | 9.43 | MEP | 2 | MB | 1631 | CON |
|  | 1.4.1.4.1.1.4.1.4.-2 | **FF_Final Fix** |  |  | 2019-08-27 | 2019-09-19 |  |  |  |  |  |  |  |  |  |  |  |
| A41312 |  | Installation of Sprinklers |  | 15d | 2019-08-27 | 2019-09-10 | A41272, A41282, A41292, 1F5-FNS-P06-850 | 163.25d | 0d |  | Fire Fighting Crew [150 h] | 14.15 | MEP | 2 | MB | 1633 | CON |
| A41322 |  | Instalaltion of Fire Extinguisher |  | 10d | 2019-09-10 | 2019-09-19 | A41272, A41312 | 163.25d | 163.75d |  | Fire Fighting Crew [100 h] | 9.43 | MEP | 2 | MB |  | CON |
| A41652 |  | Installation of Fire hose Cabinet |  | 5d | 2019-09-10 | 2019-09-15 | A41272, A41312 | 168.25d | 168.75d |  | Fire Fighting Crew [50 h] | 4.71 | MEP | 2 | MB |  |  |
|  | 1.4.32 | **B05 - MEZZAINE** |  |  | 2019-03-04 | 2019-11-27 |  |  |  |  |  |  |  |  |  |  |  |
|  | 7 | **SOUTH MEZZAINE - ZONE 4 AND 5** |  |  | 2019-03-04 | 2019-08-01 |  |  |  |  |  |  |  |  |  |  |  |
| LOE-SUM3-160 |  | South . B05 - MEP Works; 1st & 2nd Fix | level of effort | 129d | 2019-03-04 | 2019-07-02 | RM60 | 161.75d | 0d | Saudi |  |  | MEP |  |  |  |  |
| LOE-SUM3-170 |  | South . B05 - MEP Works; Final fix | level of effort | 123.5d | 2019-04-08 | 2019-08-01 | LOE-SUM3-160, A84947 SS | 217.25d | 0d | Saudi |  |  | MEP |  |  |  |  |
|  | 1 | **B05 - MEZZAINE ZONE 04** |  |  | 2019-03-24 | 2019-08-01 |  |  |  |  |  |  |  |  |  |  |  |
|  | 1.4.1.4.1.1.4.1.1 | **HVAC SYSTEM** |  |  | 2019-03-24 | 2019-07-23 |  |  |  |  |  |  |  |  |  |  |  |
|  | 1.4.1.4.1.1.4.1.1.1. | **1st Fix** |  |  | 2019-03-24 | 2019-04-09 |  |  |  |  |  |  |  |  |  |  |  |
| A84867 |  | Hanger and support Installation - Duct |  | 6d | 2019-03-24 | 2019-03-28 | RM50 | 192d | 0d |  | Mechanical Crew [60 h] | 5.66 | MEP | 4 | MB | 1546 | CON |
| A84874 |  | Hanger and support Installation - CHW |  | 6d | 2019-03-24 | 2019-03-28 | A84867 SS | 192d | 0d |  | Mechanical Crew [60 h] | 5.66 | MEP | 4 | MB |  |  |
| A84865 |  | Duct Installation |  | 12d | 2019-03-25 | 2019-04-06 | A84867 SS+2d | 231.5d | 0d |  | Duct Installation [260 Sqmt]; HVAC [780 h] | 73.55 | MEP | 4 | MB | 1549 | CON |
| A84866 |  | Duct Insulation |  | 8d | 2019-03-28 | 2019-04-04 | A84865 SS+3d | 255.5d | 98.5d |  | Duct Insulation [263 Sqmt]; HVAC [190 h] | 17.92 | MEP | 4 | MB | 1552 | CON |
| A84876 |  | Chilled Water Piping Installation |  | 12d | 2019-03-28 | 2019-04-09 | A84874 | 192d | 0d |  | Mechanical Crew [120 h] | 11.32 | MEP | 4 | MB |  |  |

| ID | WBS | Activity | Duration | Start | Finish | Predecessors | Total float | Free float | Resources | Cost | Discipline | AREA | LOCATION | MSP Activity ID | MEP-Phase |
| --- | --- | --- | --- | --- | --- | --- | --- | --- | --- | --- | --- | --- | --- | --- | --- |
|  | 1.4.1.4.1.1.4.1.1.-1 | **2nd Fix** |  | 2019-04-06 | 2019-04-28 |  |  |  |  |  |  |  |  |  |  |
| A84875 |  | Installation of Duct Accessories (VD, FD, MSD etc....) | 12d | 2019-04-06 | 2019-04-16 | A84865 | 242.5d | 85.5d | Mechanical Crew [120 h] | 11.32 | MEP | 4 | MB |  |  |
| A84885 |  | CRAC Units Installation | 15d | 2019-04-06 | 2019-04-20 | A84865 | 231.5d | 9d | Mechanical Crew [150 h] | 14.15 | MEP | 4 | MB |  |  |
| A84886 |  | FCU Installation | 15d | 2019-04-06 | 2019-04-20 | A84865 | 231.5d | 9d | Mechanical Crew [150 h] | 14.15 | MEP | 4 | MB |  |  |
| A84887 |  | VRF DX Units Installation | 12d | 2019-04-06 | 2019-04-16 | A84865 | 234.5d | 12d | Mechanical Crew [120 h] | 11.32 | MEP | 4 | MB |  |  |
| A84888 |  | Installation of Attenuators | 10d | 2019-04-06 | 2019-04-15 | A84865 | 236.5d | 14d | Mechanical Crew [100 h] | 9.43 | MEP | 4 | MB |  |  |
| A84889 |  | Installation of HVAC Fans | 10d | 2019-04-06 | 2019-04-15 | A84865 | 236.5d | 14d | Mechanical Crew [100 h] | 9.43 | MEP | 4 | MB |  |  |
| A84891 |  | Pressurization Unit | 8d | 2019-04-06 | 2019-04-13 | A84865 | 238.5d | 16d | Mechanical Crew [80 h] | 7.54 | MEP | 4 | MB |  |  |
| A84892 |  | Dosing pot | 5d | 2019-04-06 | 2019-04-10 | A84865 | 241.5d | 19d | Mechanical Crew [50 h] | 4.71 | MEP | 4 | MB |  |  |
| A84894 |  | Air Handling Units Installation | 12d | 2019-04-06 | 2019-04-16 | A84865 | 234.5d | 12d | Mechanical Crew [120 h] | 11.32 | MEP | 4 | MB |  |  |
| A84878 |  | Valves and Accessories | 10d | 2019-04-09 | 2019-04-18 | A84876 | 192d | 0d | Mechanical Crew [100 h] | 9.43 | MEP | 4 | MB |  |  |
| A84890 |  | Air-Cooled Chillers | 15d | 2019-04-09 | 2019-04-23 | A84876 | 227.5d | 5d | Mechanical Crew [150 h] | 14.15 | MEP | 4 | MB |  |  |
| A84895 |  | Chilled Water Pump Installation | 12d | 2019-04-09 | 2019-04-20 | A84876 | 230.5d | 8d | Mechanical Crew [120 h] | 11.32 | MEP | 4 | MB |  |  |
| A84879 |  | Chilled Water Pipe Insulation and Cladding | 10d | 2019-04-18 | 2019-04-28 | A84876, A84878 | 192d | 0d | Mechanical Crew [100 h] | 9.43 | MEP | 4 | MB |  |  |
|  | 1.4.1.4.1.1.4.1.1.-2 | **HVAC_Final Fix** |  | 2019-04-28 | 2019-07-23 |  |  |  |  |  |  |  |  |  |  |
| A84893 |  | Equuipment Connection | 8d | 2019-04-28 | 2019-05-05 | A84895, A84894, A84890, A84889, A84888, A84885, A84886, A84887, A84892, A84891, A84879 | 222.5d | 65.5d | Mechanical Crew [80 h] | 7.54 | MEP | 4 | MB |  |  |
| A84877 |  | Air Outlets (Grills, Diffusers, Registers etc...) | 15d | 2019-07-09 | 2019-07-23 | A84875, A84865, A84866, A84893, 1F5-FNS-B05-1080 | 157d | 147.5d | Mechanical Crew [150 h] | 14.15 | MEP | 4 | MB |  |  |
|  | 1.4.1.4.1.1.4.1.2 | **PLUMBING SYSTEM** |  | 2019-03-24 | 2019-07-17 |  |  |  |  |  |  |  |  |  |  |
|  | 1.4.1.4.1.1.4.1.2.1. | **1st Fix** |  | 2019-03-24 | 2019-04-16 |  |  |  |  |  |  |  |  |  |  |
| A84853 |  | Hanger and support Installation | 10d | 2019-03-24 | 2019-04-01 | RM50 | 188d | 0d | Plumbing Crew [100 h] | 9.43 | MEP | 4 | MB | 1566 | CON |
| A84857 |  | Drainage and Vent Pipe & Fittings | 20d | 2019-03-28 | 2019-04-15 | A84853 SS+5d | 251.5d | 1d | Plumbing Crew [200 h] | 18.86 | MEP | 4 | MB | 1573 | CON |
| A84854 |  | Domestic Water Pipe & Fittings | 20d | 2019-03-28 | 2019-04-16 | A84853 SS+6d | 188d | 0d | Plumbing Crew [200 h] | 18.86 | MEP | 4 | MB | 1570 | CON |
|  | 1.4.1.4.1.1.4.1.2.-1 | **2nd Fix** |  | 2019-04-16 | 2019-05-01 |  |  |  |  |  |  |  |  |  |  |
| A84855 |  | Domestic Water Valves | 12d | 2019-04-16 | 2019-04-28 | A84854 | 188d | 0d | Plumbing Crew [120 h] | 11.32 | MEP | 4 | MB | 1571 | CON |
| A84881 |  | Sewege Pumps Installation | 5d | 2019-04-16 | 2019-04-21 | A84857, A84854 | 250.5d | 88d | Plumbing Crew [50 h] | 4.71 | MEP | 4 | MB |  |  |
| A84856 |  | Leak Test | 4d | 2019-04-28 | 2019-05-01 | A84855 | 188d | 62d | Plumbing Crew [40 h] | 3.77 | MEP | 4 | MB | 1572 | CON |

| ID | WBS | Activity | Duration | Start | Finish | Predecessors | Total float | Free float | Resources | Cost | Discipline | AREA | LOCATION | MSP Activity ID | MEP-Phase |
| --- | --- | --- | --- | --- | --- | --- | --- | --- | --- | --- | --- | --- | --- | --- | --- |
|  | 1.4.1.4.1.1.4.1.2.-2 | **PLM_Final Fix** |  | 2019-07-16 | 2019-07-17 |  |  |  |  |  |  |  |  |  |  |
| A84880 |  | Water Heaters | 2d | 2019-07-16 | 2019-07-17 | A84856, A84857, A84854, 1F5-FNS-B05-1090 | 162.5d | 0d | Plumbing Crew [20 h] | 1.89 | MEP | 4 | MB |  |  |
| A84882 |  | Floor Drain | 2d | 2019-07-16 | 2019-07-17 | A84880 SS | 162.5d | 0d | Plumbing Crew [20 h] | 1.89 | MEP | 4 | MB |  |  |
| A84883 |  | Wash Basin / Water Closet | 2d | 2019-07-16 | 2019-07-17 | A84882 SS | 162.5d | 0d | Plumbing Crew [20 h] | 1.89 | MEP | 4 | MB |  |  |
| A84884 |  | Eye Wash | 2d | 2019-07-16 | 2019-07-17 | A84883 SS, A84881 | 162.5d | 140d | Plumbing Crew [20 h] | 1.89 | MEP | 4 | MB |  |  |
|  | 1.4.1.4.1.1.4.1.3 | **ELECTRICAL / CONTROLS** |  | 2019-03-24 | 2019-07-30 |  |  |  |  |  |  |  |  |  |  |
|  | 1.4.1.4.1.1.4.1.3.1. | **1st Fix** |  | 2019-03-24 | 2019-04-22 |  |  |  |  |  |  |  |  |  |  |
| A84863 |  | Installation of Conduits and Boxes | 12d | 2019-03-24 | 2019-04-03 | RM50 | 126d | 0d | Electrical Crew [120 h] | 11.32 | MEP | 4 | MB | 1592 | CON |
| A84864 |  | Installation of Cable Tray, Ladder and Trunk | 20d | 2019-04-03 | 2019-04-22 | A84863 | 215.5d | 0d | Electrical Crew [200 h] | 18.86 | MEP | 4 | MB | 1593 | CON |
|  | 1.4.1.4.1.1.4.1.3.-1 | **2nd Fix** |  | 2019-04-03 | 2019-07-02 |  |  |  |  |  |  |  |  |  |  |
| A84860 |  | Grounding and Bonding Installation | 20d | 2019-04-03 | 2019-04-22 | A84863 | 126d | 0d | Electrical Crew [200 h] | 18.86 | MEP | 4 | MB | 1596 | CON |
| A84896 |  | Wire Pulling | 20d | 2019-04-22 | 2019-05-11 | A84860 | 126d | 0d | Electrical Crew [200 h] | 18.86 | MEP | 4 | MB |  |  |
| A84902 |  | Installation of Bus Duct System | 20d | 2019-04-22 | 2019-05-11 | A84864 | 215.5d | 67d | Electrical Crew [200 h] | 18.86 | MEP | 4 | MB |  |  |
| A84858 |  | Power Cable Laying | 25d | 2019-05-11 | 2019-06-03 | A84896, A84860 | 126d | 0d | Electrical Crew [250 h] | 23.58 | MEP | 4 | MB | 1600 | CON |
| A84859 |  | Continuity Test - Power Cables | 4d | 2019-06-03 | 2019-06-10 | A84858 | 186.5d | 38d | Electrical Crew [40 h] | 3.77 | MEP | 4 | MB | 1601 | CON |
| A84897 |  | Installation of Central Battery Equipment | 6d | 2019-06-03 | 2019-06-12 | A84858, A84896 | 184.5d | 36d | Electrical Crew [60 h] | 5.66 | MEP | 4 | MB |  |  |
| A84898 |  | Installation of Disconnect Switch | 8d | 2019-06-03 | 2019-06-13 | A84858, A84896 | 182.5d | 34d | Electrical Crew [80 h] | 7.54 | MEP | 4 | MB |  |  |
| A84900 |  | Installation of Switch Boards (MDB, EMDB) | 15d | 2019-06-03 | 2019-06-20 | A84858, A84896 | 126d | 0d | Electrical Crew [150 h] | 14.15 | MEP | 4 | MB |  |  |
| A84901 |  | Installation of Panel Boards | 15d | 2019-06-03 | 2019-06-20 | A84858, A84896 | 126d | 0d | Electrical Crew [150 h] | 14.15 | MEP | 4 | MB |  |  |
| A84903 |  | Installation of MCC | 15d | 2019-06-03 | 2019-06-20 | A84858, A84896 | 126d | 0d | Electrical Crew [150 h] | 14.15 | MEP | 4 | MB |  |  |
| A84904 |  | Installation of Lighting Control System | 12d | 2019-06-03 | 2019-06-18 | A84858, A84896 | 129d | 3d | Electrical Crew [120 h] | 11.32 | MEP | 4 | MB |  |  |
| A84899 |  | Installation of Wiring Devices and Outlets | 12d | 2019-06-20 | 2019-07-02 | A84896, A84903, A84901, A84900, A84904 | 126d | 0d | Electrical Crew [120 h] | 11.32 | MEP | 4 | MB |  |  |
|  | 1.4.1.4.1.1.4.1.3.-2 | **Elec._Final Fix** |  | 2019-06-20 | 2019-07-30 |  |  |  |  |  |  |  |  |  |  |
| A84905 |  | Panel Board Termination | 8d | 2019-06-20 | 2019-06-27 | A84900, A84901, A84903 | 173.5d | 25d | Electrical Crew [80 h] | 7.54 | MEP | 4 | MB |  |  |
| A84862 |  | Wiring devices Termination | 6d | 2019-07-16 | 2019-07-21 | A84897, A84898, A84902, A84904, A84899, A84859, 1F5-FNS-B05-1090 | 148.5d | 0d | Electrical Crew [60 h] | 5.66 | MEP | 4 | MB | 1617 | CON |
| A84861 |  | Lighting Fixtures Installation and Termination | 10d | 2019-07-22 | 2019-07-30 | A84858, A84896, A84905, A84862, 1F5-FNS-B05-1080, LOE-SUM3-170 FF | 148.5d | 134d | Electrical Crew [100 h] | 9.43 | MEP | 4 | MB | 1616 | CON |

| ID | WBS | Activity | Duration | Start | Finish | Predecessors | Total float | Free float | Resources | Cost | MSP Activity ID | Discipline | MEP-Phase | AREA | LOCATION |
| --- | --- | --- | --- | --- | --- | --- | --- | --- | --- | --- | --- | --- | --- | --- | --- |
|  | 1.4.1.4.1.1.4.1.4 | **FIRE FIGHTING SYSTEM** |  | 2019-03-24 | 2019-08-01 |  |  |  |  |  |  |  |  |  |  |
|  | 1.4.1.4.1.1.4.1.4.1. | **1st Fix** |  | 2019-03-24 | 2019-05-04 |  |  |  |  |  |  |  |  |  |  |
| A84871 |  | Fire Fighting Hangers & Supports | 15d | 2019-03-24 | 2019-04-06 | RM50 | 155d | 0d | Fire Fighting Crew [150 h] | 14.15 | 1622 | MEP | CON | 4 | MB |
| A84868 |  | Pipe Installation | 30d | 2019-04-07 | 2019-05-04 | A84871 | 155d | 0d | FF pipe [206 Limt]; FIRE FIGHTING [361 h] | 34.04 | 1625 | MEP | CON | 4 | MB |
|  | 1.4.1.4.1.1.4.1.4.-1 | **2nd Fix** |  | 2019-05-05 | 2019-06-01 |  |  |  |  |  |  |  |  |  |  |
| A84869 |  | Valve and Accessories Installation | 20d | 2019-05-05 | 2019-05-22 | A84868, A84871 | 155d | 0d | Fire Fighting Crew [200 h] | 18.86 | 1627 | MEP | CON | 4 | MB |
| A84870 |  | Leak Test | 10d | 2019-05-23 | 2019-06-01 | A84869 | 155d | 29d | Fire Fighting Crew [100 h] | 9.43 | 1631 | MEP | CON | 4 | MB |
|  | 1.4.1.4.1.1.4.1.4.-2 | **FF_Final Fix** |  | 2019-07-09 | 2019-08-01 |  |  |  |  |  |  |  |  |  |  |
| A84872 |  | Installation of Sprinklers | 15d | 2019-07-09 | 2019-07-23 | A84868, A84869, A84870, 1F5-FNS-B05-1080 | 157d | 0d | Fire Fighting Crew [150 h] | 14.15 | 1633 | MEP | CON | 4 | MB |
| A84873 |  | Instalaltion of Fire Extinguisher | 10d | 2019-07-23 | 2019-08-01 | A84868, A84872, A84906 FF, LOE-SUM3-170 FF | 212d | 212.5d | Fire Fighting Crew [100 h] | 9.43 |  | MEP | CON | 4 | MB |
| A84906 |  | Installation of Fire hose Cabinet | 5d | 2019-07-23 | 2019-07-28 | A84868, A84872 | 217d | 5d | Fire Fighting Crew [50 h] | 4.71 |  | MEP |  | 4 | MB |
|  | 2 | **B05 - MEZZAINE ZONE 05** |  | 2019-03-04 | 2019-07-13 |  |  |  |  |  |  |  |  |  |  |
|  | 1.4.1.4.1.1.4.1.1 | **HVAC SYSTEM** |  | 2019-03-04 | 2019-07-03 |  |  |  |  |  |  |  |  |  |  |
|  | 1.4.1.4.1.1.4.1.1.1. | **1st Fix** |  | 2019-03-04 | 2019-03-20 |  |  |  |  |  |  |  |  |  |  |
| A84921 |  | Hanger and support Installation - Duct | 6d | 2019-03-04 | 2019-03-09 | RM60 | 205.75d | 0d | Mechanical Crew [60 h] | 5.66 | 1546 | MEP | CON | 5 | MB |
| A84928 |  | Hanger and support Installation - CHW | 6d | 2019-03-04 | 2019-03-09 | A84921 SS | 205.75d | 0d | Mechanical Crew [60 h] | 5.66 |  | MEP |  | 5 | MB |
| A84919 |  | Duct Installation | 12d | 2019-03-05 | 2019-03-17 | A84921 SS+2d | 252.75d | 0d | Duct Installation [260 Sqmt]; HVAC [780 h] | 73.55 | 1549 | MEP | CON | 5 | MB |
| A84920 |  | Duct Insulation | 8d | 2019-03-09 | 2019-03-16 | A84919 SS+3d | 276.75d | 98.5d | Duct Insulation [263 Sqmt]; HVAC [190 h] | 17.92 | 1552 | MEP | CON | 5 | MB |
| A84930 |  | Chilled Water Piping Installation | 12d | 2019-03-09 | 2019-03-20 | A84928 | 205.75d | 0d | Mechanical Crew [120 h] | 11.32 |  | MEP |  | 5 | MB |
|  | 1.4.1.4.1.1.4.1.1.-1 | **2nd Fix** |  | 2019-03-17 | 2019-04-08 |  |  |  |  |  |  |  |  |  |  |
| A84929 |  | Installation of Duct Accessories (VD, FD, MSD etc....) | 12d | 2019-03-17 | 2019-03-27 | A84919 | 263.75d | 85.5d | Mechanical Crew [120 h] | 11.32 |  | MEP |  | 5 | MB |
| A84939 |  | CRAC Units Installation | 15d | 2019-03-17 | 2019-03-31 | A84919 | 252.75d | 9d | Mechanical Crew [150 h] | 14.15 |  | MEP |  | 5 | MB |
| A84940 |  | FCU Installation | 15d | 2019-03-17 | 2019-03-31 | A84919 | 252.75d | 9d | Mechanical Crew [150 h] | 14.15 |  | MEP |  | 5 | MB |
| A84941 |  | VRF DX Units Installation | 12d | 2019-03-17 | 2019-03-27 | A84919 | 255.75d | 12d | Mechanical Crew [120 h] | 11.32 |  | MEP |  | 5 | MB |
| A84942 |  | Installation of Attenuators | 10d | 2019-03-17 | 2019-03-26 | A84919 | 257.75d | 14d | Mechanical Crew [100 h] | 9.43 |  | MEP |  | 5 | MB |
| A84943 |  | Installation of HVAC Fans | 10d | 2019-03-17 | 2019-03-26 | A84919 | 257.75d | 14d | Mechanical Crew [100 h] | 9.43 |  | MEP |  | 5 | MB |
| A84945 |  | Pressurization Unit | 8d | 2019-03-17 | 2019-03-24 | A84919 | 259.75d | 16d | Mechanical Crew [80 h] | 7.54 |  | MEP |  | 5 | MB |
| A84946 |  | Dosing pot | 5d | 2019-03-17 | 2019-03-21 | A84919 | 262.75d | 19d | Mechanical Crew [50 h] | 4.71 |  | MEP |  | 5 | MB |
| A84948 |  | Air Handling Units Installation | 12d | 2019-03-17 | 2019-03-27 | A84919 | 255.75d | 12d | Mechanical Crew [120 h] | 11.32 |  | MEP |  | 5 | MB |
| A84932 |  | Valves and Accessories | 10d | 2019-03-20 | 2019-03-30 | A84930 | 205.75d | 0d | Mechanical Crew [100 h] | 9.43 |  | MEP |  | 5 | MB |
| A84944 |  | Air-Cooled Chillers | 15d | 2019-03-20 | 2019-04-03 | A84930 | 248.75d | 5d | Mechanical Crew [150 h] | 14.15 |  | MEP |  | 5 | MB |
| A84949 |  | Chilled Water Pump Installation | 12d | 2019-03-20 | 2019-03-31 | A84930 | 251.75d | 8d | Mechanical Crew [120 h] | 11.32 |  | MEP |  | 5 | MB |
| A84933 |  | Chilled Water Pipe Insulation and Cladding | 10d | 2019-03-30 | 2019-04-08 | A84930, A84932 | 205.75d | 0d | Mechanical Crew [100 h] | 9.43 |  | MEP |  | 5 | MB |

| ID | WBS | Activity | Duration | Start | Finish | Predecessors | Total float | Free float | Resources | Cost | Discipline | AREA | LOCATION | MSP Activity ID | MEP-Phase |
| --- | --- | --- | --- | --- | --- | --- | --- | --- | --- | --- | --- | --- | --- | --- | --- |
|  | 1.4.1.4.1.1.4.1.1.-2 | **HVAC_Final Fix** |  | 2019-04-08 | 2019-07-03 |  |  |  |  |  |  |  |  |  |  |
| A84947 |  | Equuipment Connection | 8d | 2019-04-08 | 2019-04-15 | A84949, A84948, A84944, A84943, A84942, A84939, A84940, A84941, A84946, A84945, A84933 | 243.75d | 65.5d | Mechanical Crew [80 h] | 7.54 | MEP | 5 | MB |  |  |
| A84931 |  | Air Outlets (Grills, Diffusers, Registers etc...) | 15d | 2019-06-19 | 2019-07-03 | A84929, A84919, A84920, A84947, 1F5-FNS-B05-950 | 178.25d | 168.75d | Mechanical Crew [150 h] | 14.15 | MEP | 5 | MB |  |  |
|  | 1.4.1.4.1.1.4.1.2 | **PLUMBING SYSTEM** |  | 2019-03-04 | 2019-06-27 |  |  |  |  |  |  |  |  |  |  |
|  | 1.4.1.4.1.1.4.1.2.1. | **1st Fix** |  | 2019-03-04 | 2019-03-27 |  |  |  |  |  |  |  |  |  |  |
| A84907 |  | Hanger and support Installation | 10d | 2019-03-04 | 2019-03-12 | RM60 | 201.75d | 0d | Plumbing Crew [100 h] | 9.43 | MEP | 5 | MB | 1566 | CON |
| A84911 |  | Drainage and Vent Pipe & Fittings | 20d | 2019-03-09 | 2019-03-26 | A84907 SS+5d | 272.75d | 1d | Plumbing Crew [200 h] | 18.86 | MEP | 5 | MB | 1573 | CON |
| A84908 |  | Domestic Water Pipe & Fittings | 20d | 2019-03-09 | 2019-03-27 | A84907 SS+6d | 201.75d | 0d | Plumbing Crew [200 h] | 18.86 | MEP | 5 | MB | 1570 | CON |
|  | 1.4.1.4.1.1.4.1.2.-1 | **2nd Fix** |  | 2019-03-27 | 2019-04-11 |  |  |  |  |  |  |  |  |  |  |
| A84909 |  | Domestic Water Valves | 12d | 2019-03-27 | 2019-04-08 | A84908 | 201.75d | 0d | Plumbing Crew [120 h] | 11.32 | MEP | 5 | MB | 1571 | CON |
| A84935 |  | Sewege Pumps Installation | 5d | 2019-03-27 | 2019-04-01 | A84911, A84908 | 271.75d | 88d | Plumbing Crew [50 h] | 4.71 | MEP | 5 | MB |  |  |
| A84910 |  | Leak Test | 4d | 2019-04-08 | 2019-04-11 | A84909 | 201.75d | 62d | Plumbing Crew [40 h] | 3.77 | MEP | 5 | MB | 1572 | CON |
|  | 1.4.1.4.1.1.4.1.2.-2 | **PLM_Final Fix** |  | 2019-06-26 | 2019-06-27 |  |  |  |  |  |  |  |  |  |  |
| A84934 |  | Water Heaters | 2d | 2019-06-26 | 2019-06-27 | A84910, A84911, A84908, 1F5-FNS-B05-960 | 183.75d | 0d | Plumbing Crew [20 h] | 1.89 | MEP | 5 | MB |  |  |
| A84936 |  | Floor Drain | 2d | 2019-06-26 | 2019-06-27 | A84934 SS | 183.75d | 0d | Plumbing Crew [20 h] | 1.89 | MEP | 5 | MB |  |  |
| A84937 |  | Wash Basin / Water Closet | 2d | 2019-06-26 | 2019-06-27 | A84936 SS | 183.75d | 0d | Plumbing Crew [20 h] | 1.89 | MEP | 5 | MB |  |  |
| A84938 |  | Eye Wash | 2d | 2019-06-26 | 2019-06-27 | A84937 SS, A84935 | 183.75d | 161.25d | Plumbing Crew [20 h] | 1.89 | MEP | 5 | MB |  |  |
|  | 1.4.1.4.1.1.4.1.3 | **ELECTRICAL / CONTROLS** |  | 2019-03-04 | 2019-07-10 |  |  |  |  |  |  |  |  |  |  |
|  | 1.4.1.4.1.1.4.1.3.1. | **1st Fix** |  | 2019-03-04 | 2019-03-21 |  |  |  |  |  |  |  |  |  |  |
| A84917 |  | Installation of Conduits and Boxes | 12d | 2019-03-04 | 2019-03-14 | RM60 | 139.75d | 0d | Electrical Crew [120 h] | 11.32 | MEP | 5 | MB | 1592 | CON |
| A84918 |  | Installation of Cable Tray, Ladder and Trunk | 20d | 2019-03-04 | 2019-03-21 | A84917 SF, RM60 | 248.75d | 0d | Electrical Crew [200 h] | 18.86 | MEP | 5 | MB | 1593 | CON |
|  | 1.4.1.4.1.1.4.1.3.-1 | **2nd Fix** |  | 2019-03-14 | 2019-06-12 |  |  |  |  |  |  |  |  |  |  |
| A84914 |  | Grounding and Bonding Installation | 20d | 2019-03-14 | 2019-04-02 | A84917 | 139.75d | 0d | Electrical Crew [200 h] | 18.86 | MEP | 5 | MB | 1596 | CON |
| A84956 |  | Installation of Bus Duct System | 20d | 2019-03-23 | 2019-04-09 | A84918 | 248.75d | 79d | Electrical Crew [200 h] | 18.86 | MEP | 5 | MB |  |  |
| A84950 |  | Wire Pulling | 20d | 2019-04-02 | 2019-04-21 | A84914 | 139.75d | 0d | Electrical Crew [200 h] | 18.86 | MEP | 5 | MB |  |  |
| A84912 |  | Power Cable Laying | 25d | 2019-04-21 | 2019-05-14 | A84950, A84914 | 139.75d | 0d | Electrical Crew [250 h] | 23.58 | MEP | 5 | MB | 1600 | CON |
| A84913 |  | Continuity Test - Power Cables | 4d | 2019-05-14 | 2019-05-18 | A84912 | 207.75d | 38d | Electrical Crew [40 h] | 3.77 | MEP | 5 | MB | 1601 | CON |
| A84951 |  | Installation of Central Battery Equipment | 6d | 2019-05-14 | 2019-05-20 | A84912, A84950 | 205.75d | 36d | Electrical Crew [60 h] | 5.66 | MEP | 5 | MB |  |  |
| A84952 |  | Installation of Disconnect Switch | 8d | 2019-05-14 | 2019-05-21 | A84912, A84950 | 203.75d | 34d | Electrical Crew [80 h] | 7.54 | MEP | 5 | MB |  |  |
| A84954 |  | Installation of Switch Boards (MDB, EMDB) | 15d | 2019-05-14 | 2019-05-28 | A84912, A84950 | 139.75d | 0d | Electrical Crew [150 h] | 14.15 | MEP | 5 | MB |  |  |
| A84955 |  | Installation of Panel Boards | 15d | 2019-05-14 | 2019-05-28 | A84912, A84950 | 139.75d | 0d | Electrical Crew [150 h] | 14.15 | MEP | 5 | MB |  |  |
| A84957 |  | Installation of MCC | 15d | 2019-05-14 | 2019-05-28 | A84912, A84950 | 139.75d | 0d | Electrical Crew [150 h] | 14.15 | MEP | 5 | MB |  |  |
| A84958 |  | Installation of Lighting Control System | 12d | 2019-05-14 | 2019-05-26 | A84912, A84950 | 142.75d | 3d | Electrical Crew [120 h] | 11.32 | MEP | 5 | MB |  |  |
| A84953 |  | Installation of Wiring Devices and Outlets | 12d | 2019-05-28 | 2019-06-12 | A84950, A84957, A84955, A84954, A84958 | 139.75d | 0d | Electrical Crew [120 h] | 11.32 | MEP | 5 | MB |  |  |

| ID | WBS | Activity | Type | Duration | Start | Finish | Predecessors | Total float | Free float | Calendar | Resources | Cost | Discipline | AREA | LOCATION | MSP Activity ID | MEP-Phase |
| --- | --- | --- | --- | --- | --- | --- | --- | --- | --- | --- | --- | --- | --- | --- | --- | --- | --- |
|  | 1.4.1.4.1.1.4.1.3.-2 | **Elec._Final Fix** |  |  | 2019-05-28 | 2019-07-10 |  |  |  |  |  |  |  |  |  |  |  |
| A84959 |  | Panel Board Termination |  | 8d | 2019-05-28 | 2019-06-08 | A84954, A84955, A84957 | 194.75d | 25d |  | Electrical Crew [80 h] | 7.54 | MEP | 5 | MB |  |  |
| A84916 |  | Wiring devices Termination |  | 6d | 2019-06-26 | 2019-07-01 | A84951, A84952, A84956, A84958, A84953, A84913, 1F5-FNS-B05-960 | 169.75d | 0d |  | Electrical Crew [60 h] | 5.66 | MEP | 5 | MB | 1617 | CON |
| A84915 |  | Lighting Fixtures Installation and Termination |  | 10d | 2019-07-02 | 2019-07-10 | A84912, A84950, A84959, A84916, 1F5-FNS-B05-950 | 169.75d | 155.25d |  | Electrical Crew [100 h] | 9.43 | MEP | 5 | MB | 1616 | CON |
|  | 1.4.1.4.1.1.4.1.4 | **FIRE FIGHTING SYSTEM** |  |  | 2019-03-04 | 2019-07-13 |  |  |  |  |  |  |  |  |  |  |  |
|  | 1.4.1.4.1.1.4.1.4.1. | **1st Fix** |  |  | 2019-03-04 | 2019-04-14 |  |  |  |  |  |  |  |  |  |  |  |
| A84925 |  | Fire Fighting Hangers & Supports |  | 15d | 2019-03-04 | 2019-03-17 | RM60 | 168.75d | 0d |  | Fire Fighting Crew [150 h] | 14.15 | MEP | 5 | MB | 1622 | CON |
| A84922 |  | Pipe Installation |  | 30d | 2019-03-18 | 2019-04-14 | A84925 | 168.75d | 0d |  | FIRE FIGHTING [361 h]; FF pipe [206 Limt] | 34.04 | MEP | 5 | MB | 1625 | CON |
|  | 1.4.1.4.1.1.4.1.4.-1 | **2nd Fix** |  |  | 2019-04-15 | 2019-05-12 |  |  |  |  |  |  |  |  |  |  |  |
| A84923 |  | Valve and Accessories Installation |  | 20d | 2019-04-15 | 2019-05-02 | A84922, A84925 | 168.75d | 0d |  | Fire Fighting Crew [200 h] | 18.86 | MEP | 5 | MB | 1627 | CON |
| A84924 |  | Leak Test |  | 10d | 2019-05-04 | 2019-05-12 | A84923 | 168.75d | 29d |  | Fire Fighting Crew [100 h] | 9.43 | MEP | 5 | MB | 1631 | CON |
|  | 1.4.1.4.1.1.4.1.4.-2 | **FF_Final Fix** |  |  | 2019-06-19 | 2019-07-13 |  |  |  |  |  |  |  |  |  |  |  |
| A84926 |  | Installation of Sprinklers |  | 15d | 2019-06-19 | 2019-07-03 | A84922, A84923, A84924, 1F5-FNS-B05-950 | 178.25d | 0d |  | Fire Fighting Crew [150 h] | 14.15 | MEP | 5 | MB | 1633 | CON |
| A84927 |  | Instalaltion of Fire Extinguisher |  | 10d | 2019-07-03 | 2019-07-13 | A84922, A84926, A84960 FF | 233.25d | 233.75d |  | Fire Fighting Crew [100 h] | 9.43 | MEP | 5 | MB |  | CON |
| A84960 |  | Installation of Fire hose Cabinet |  | 5d | 2019-07-03 | 2019-07-08 | A84922, A84926 | 238.25d | 5d |  | Fire Fighting Crew [50 h] | 4.71 | MEP | 5 | MB |  |  |
|  | 6 | **CENTRAL MEZZAINE - ZONE 03** |  |  | 2019-05-09 | 2019-09-21 |  |  |  |  |  |  |  |  |  |  |  |
| LOE-SUM3-180 |  | Central . B05 - MEP Works; 1st & 2nd Fix | level of effort | 111.5d | 2019-05-09 | 2019-08-21 | RM70 | 108d | 0d | Saudi |  |  | MEP |  |  |  |  |
| LOE-SUM3-190 |  | Central . B05 - MEP Works; Final fix | level of effort | 102.25d | 2019-06-17 | 2019-09-21 | LOE-SUM3-180, A85001 SS | 163.5d | 0d | Saudi |  |  | MEP |  |  |  |  |
|  | 3 | **B05 - MEZZAINE ZONE 03** |  |  | 2019-05-09 | 2019-09-21 |  |  |  |  |  |  |  |  |  |  |  |
|  | 1.4.1.4.1.1.4.1.1 | **HVAC SYSTEM** |  |  | 2019-05-09 | 2019-09-11 |  |  |  |  |  |  |  |  |  |  |  |
|  | 1.4.1.4.1.1.4.1.1.1. | **1st Fix** |  |  | 2019-05-09 | 2019-05-26 |  |  |  |  |  |  |  |  |  |  |  |
| A84975 |  | Hanger and support Installation - Duct |  | 6d | 2019-05-09 | 2019-05-14 | RM70 | 149.5d | 0d |  | Mechanical Crew [60 h] | 5.66 | MEP | 3 | MB | 1546 | CON |
| A84982 |  | Hanger and support Installation - CHW |  | 6d | 2019-05-09 | 2019-05-14 | A84975 SS | 149.5d | 0d |  | Mechanical Crew [60 h] | 5.66 | MEP | 3 | MB |  |  |
| A84973 |  | Duct Installation |  | 12d | 2019-05-11 | 2019-05-22 | A84975 SS+2d | 181.5d | 0d |  | Duct Installation [520 Sqmt]; HVAC [1560 h] | 147.11 | MEP | 3 | MB | 1549 | CON |
| A84974 |  | Duct Insulation |  | 8d | 2019-05-14 | 2019-05-21 | A84973 SS+3d | 205.5d | 98.5d |  | Duct Insulation [535 Sqmt]; HVAC [380 h] | 35.83 | MEP | 3 | MB | 1552 | CON |
| A84984 |  | Chilled Water Piping Installation |  | 12d | 2019-05-14 | 2019-05-26 | A84982 | 149.5d | 0d |  | Mechanical Crew [120 h] | 11.32 | MEP | 3 | MB |  |  |

| ID | WBS | Activity | Duration | Start | Finish | Predecessors | Total float | Free float | Resources | Cost | Discipline | AREA | LOCATION | MSP Activity ID | MEP-Phase |
| --- | --- | --- | --- | --- | --- | --- | --- | --- | --- | --- | --- | --- | --- | --- | --- |
|  | 1.4.1.4.1.1.4.1.1.-1 | **2nd Fix** |  | 2019-05-22 | 2019-06-17 |  |  |  |  |  |  |  |  |  |  |
| A84983 |  | Installation of Duct Accessories (VD, FD, MSD etc....) | 12d | 2019-05-22 | 2019-06-02 | A84973 | 192.5d | 85.5d | Mechanical Crew [120 h] | 11.32 | MEP | 3 | MB |  |  |
| A84993 |  | CRAC Units Installation | 15d | 2019-05-22 | 2019-06-09 | A84973 | 181.5d | 9d | Mechanical Crew [150 h] | 14.15 | MEP | 3 | MB |  |  |
| A84994 |  | FCU Installation | 15d | 2019-05-22 | 2019-06-09 | A84973 | 181.5d | 9d | Mechanical Crew [150 h] | 14.15 | MEP | 3 | MB |  |  |
| A84995 |  | VRF DX Units Installation | 12d | 2019-05-22 | 2019-06-02 | A84973 | 184.5d | 12d | Mechanical Crew [120 h] | 11.32 | MEP | 3 | MB |  |  |
| A84996 |  | Installation of Attenuators | 10d | 2019-05-22 | 2019-06-01 | A84973 | 186.5d | 14d | Mechanical Crew [100 h] | 9.43 | MEP | 3 | MB |  |  |
| A84997 |  | Installation of HVAC Fans | 10d | 2019-05-22 | 2019-06-01 | A84973 | 186.5d | 14d | Mechanical Crew [100 h] | 9.43 | MEP | 3 | MB |  |  |
| A84999 |  | Pressurization Unit | 8d | 2019-05-22 | 2019-05-29 | A84973 | 188.5d | 16d | Mechanical Crew [80 h] | 7.54 | MEP | 3 | MB |  |  |
| A85000 |  | Dosing pot | 5d | 2019-05-22 | 2019-05-27 | A84973 | 191.5d | 19d | Mechanical Crew [50 h] | 4.71 | MEP | 3 | MB |  |  |
| A85002 |  | Air Handling Units Installation | 12d | 2019-05-22 | 2019-06-02 | A84973 | 184.5d | 12d | Mechanical Crew [120 h] | 11.32 | MEP | 3 | MB |  |  |
| A84986 |  | Valves and Accessories | 10d | 2019-05-26 | 2019-06-08 | A84984 | 149.5d | 0d | Mechanical Crew [100 h] | 9.43 | MEP | 3 | MB |  |  |
| A84998 |  | Air-Cooled Chillers | 15d | 2019-05-26 | 2019-06-12 | A84984 | 177.5d | 5d | Mechanical Crew [150 h] | 14.15 | MEP | 3 | MB |  |  |
| A85003 |  | Chilled Water Pump Installation | 12d | 2019-05-26 | 2019-06-09 | A84984 | 180.5d | 8d | Mechanical Crew [120 h] | 11.32 | MEP | 3 | MB |  |  |
| A84987 |  | Chilled Water Pipe Insulation and Cladding | 10d | 2019-06-08 | 2019-06-17 | A84984, A84986 | 149.5d | 0d | Mechanical Crew [100 h] | 9.43 | MEP | 3 | MB |  |  |
|  | 1.4.1.4.1.1.4.1.1.-2 | **HVAC_Final Fix** |  | 2019-06-17 | 2019-09-11 |  |  |  |  |  |  |  |  |  |  |
| A85001 |  | Equuipment Connection | 8d | 2019-06-17 | 2019-06-24 | A85003, A85002, A84998, A84997, A84996, A84993, A84994, A84995, A85000, A84999, A84987 | 172.5d | 65.5d | Mechanical Crew [80 h] | 7.54 | MEP | 3 | MB |  |  |
| A84985 |  | Air Outlets (Grills, Diffusers, Registers etc...) | 15d | 2019-08-28 | 2019-09-11 | A84983, A84973, A84974, A85001, 1F5-FNS-B05-1220 | 107d | 97.5d | Mechanical Crew [150 h] | 14.15 | MEP | 3 | MB |  |  |
|  | 1.4.1.4.1.1.4.1.2 | **PLUMBING SYSTEM** |  | 2019-05-09 | 2019-09-05 |  |  |  |  |  |  |  |  |  |  |
|  | 1.4.1.4.1.1.4.1.2.1. | **1st Fix** |  | 2019-05-09 | 2019-06-02 |  |  |  |  |  |  |  |  |  |  |
| A84961 |  | Hanger and support Installation | 10d | 2019-05-09 | 2019-05-18 | RM70 | 145.5d | 0d | Plumbing Crew [100 h] | 9.43 | MEP | 3 | MB | 1566 | CON |
| A84965 |  | Drainage and Vent Pipe & Fittings | 20d | 2019-05-14 | 2019-06-01 | A84961 SS+5d | 201.5d | 1d | Plumbing Crew [200 h] | 18.86 | MEP | 3 | MB | 1573 | CON |
| A84962 |  | Domestic Water Pipe & Fittings | 20d | 2019-05-14 | 2019-06-02 | A84961 SS+6d | 145.5d | 0d | Plumbing Crew [200 h] | 18.86 | MEP | 3 | MB | 1570 | CON |
|  | 1.4.1.4.1.1.4.1.2.-1 | **2nd Fix** |  | 2019-06-02 | 2019-06-20 |  |  |  |  |  |  |  |  |  |  |
| A84963 |  | Domestic Water Valves | 12d | 2019-06-02 | 2019-06-17 | A84962 | 145.5d | 0d | Plumbing Crew [120 h] | 11.32 | MEP | 3 | MB | 1571 | CON |
| A84989 |  | Sewege Pumps Installation | 5d | 2019-06-02 | 2019-06-10 | A84965, A84962 | 200.5d | 88d | Plumbing Crew [50 h] | 4.71 | MEP | 3 | MB |  |  |
| A84964 |  | Leak Test | 4d | 2019-06-17 | 2019-06-20 | A84963 | 145.5d | 62d | Plumbing Crew [40 h] | 3.77 | MEP | 3 | MB | 1572 | CON |

| ID | WBS | Activity | Duration | Start | Finish | Predecessors | Total float | Free float | Resources | Cost | Discipline | AREA | LOCATION | MSP Activity ID | MEP-Phase |
| --- | --- | --- | --- | --- | --- | --- | --- | --- | --- | --- | --- | --- | --- | --- | --- |
|  | 1.4.1.4.1.1.4.1.2.-2 | **PLM_Final Fix** |  | 2019-09-04 | 2019-09-05 |  |  |  |  |  |  |  |  |  |  |
| A84988 |  | Water Heaters | 2d | 2019-09-04 | 2019-09-05 | A84964, A84965, A84962, 1F5-FNS-B05-1225 | 112.5d | 0d | Plumbing Crew [20 h] | 1.89 | MEP | 3 | MB |  |  |
| A84990 |  | Floor Drain | 2d | 2019-09-04 | 2019-09-05 | A84988 SS | 112.5d | 0d | Plumbing Crew [20 h] | 1.89 | MEP | 3 | MB |  |  |
| A84991 |  | Wash Basin / Water Closet | 2d | 2019-09-04 | 2019-09-05 | A84990 SS | 112.5d | 0d | Plumbing Crew [20 h] | 1.89 | MEP | 3 | MB |  |  |
| A84992 |  | Eye Wash | 2d | 2019-09-04 | 2019-09-05 | A84991 SS, A84989 | 112.5d | 90d | Plumbing Crew [20 h] | 1.89 | MEP | 3 | MB |  |  |
|  | 1.4.1.4.1.1.4.1.3 | **ELECTRICAL / CONTROLS** |  | 2019-05-09 | 2019-09-18 |  |  |  |  |  |  |  |  |  |  |
|  | 1.4.1.4.1.1.4.1.3.1. | **1st Fix** |  | 2019-05-09 | 2019-06-11 |  |  |  |  |  |  |  |  |  |  |
| A84971 |  | Installation of Conduits and Boxes | 12d | 2019-05-09 | 2019-05-20 | RM70 | 83.5d | 0d | Electrical Crew [120 h] | 11.32 | MEP | 3 | MB | 1592 | CON |
| A84972 |  | Installation of Cable Tray, Ladder and Trunk | 20d | 2019-05-20 | 2019-06-11 | A84971 | 165.5d | 0d | Electrical Crew [200 h] | 18.86 | MEP | 3 | MB | 1593 | CON |
|  | 1.4.1.4.1.1.4.1.3.-1 | **2nd Fix** |  | 2019-05-20 | 2019-08-21 |  |  |  |  |  |  |  |  |  |  |
| A84968 |  | Grounding and Bonding Installation | 20d | 2019-05-20 | 2019-06-11 | A84971 | 83.5d | 0d | Electrical Crew [200 h] | 18.86 | MEP | 3 | MB | 1596 | CON |
| A85004 |  | Wire Pulling | 20d | 2019-06-11 | 2019-06-30 | A84968 | 83.5d | 0d | Electrical Crew [200 h] | 18.86 | MEP | 3 | MB |  |  |
| A85010 |  | Installation of Bus Duct System | 20d | 2019-06-11 | 2019-06-30 | A84972 | 165.5d | 67d | Electrical Crew [200 h] | 18.86 | MEP | 3 | MB |  |  |
| A84966 |  | Power Cable Laying | 25d | 2019-06-30 | 2019-07-23 | A85004, A84968 | 83.5d | 0d | Electrical Crew [250 h] | 23.58 | MEP | 3 | MB | 1600 | CON |
| A84967 |  | Continuity Test - Power Cables | 4d | 2019-07-23 | 2019-07-27 | A84966 | 136.5d | 38d | Electrical Crew [40 h] | 3.77 | MEP | 3 | MB | 1601 | CON |
| A85005 |  | Installation of Central Battery Equipment | 6d | 2019-07-23 | 2019-07-29 | A84966, A85004 | 134.5d | 36d | Electrical Crew [60 h] | 5.66 | MEP | 3 | MB |  |  |
| A85006 |  | Installation of Disconnect Switch | 8d | 2019-07-23 | 2019-07-30 | A84966, A85004 | 132.5d | 34d | Electrical Crew [80 h] | 7.54 | MEP | 3 | MB |  |  |
| A85008 |  | Installation of Switch Boards (MDB, EMDB) | 15d | 2019-07-23 | 2019-08-06 | A84966, A85004 | 83.5d | 0d | Electrical Crew [150 h] | 14.15 | MEP | 3 | MB |  |  |
| A85009 |  | Installation of Panel Boards | 15d | 2019-07-23 | 2019-08-06 | A84966, A85004 | 83.5d | 0d | Electrical Crew [150 h] | 14.15 | MEP | 3 | MB |  |  |
| A85011 |  | Installation of MCC | 15d | 2019-07-23 | 2019-08-06 | A84966, A85004 | 83.5d | 0d | Electrical Crew [150 h] | 14.15 | MEP | 3 | MB |  |  |
| A85012 |  | Installation of Lighting Control System | 12d | 2019-07-23 | 2019-08-04 | A84966, A85004 | 86.5d | 3d | Electrical Crew [120 h] | 11.32 | MEP | 3 | MB |  |  |
| A85007 |  | Installation of Wiring Devices and Outlets | 12d | 2019-08-06 | 2019-08-21 | A85004, A85011, A85009, A85008, A85012 | 83.5d | 0d | Electrical Crew [120 h] | 11.32 | MEP | 3 | MB |  |  |
|  | 1.4.1.4.1.1.4.1.3.-2 | **Elec._Final Fix** |  | 2019-08-06 | 2019-09-18 |  |  |  |  |  |  |  |  |  |  |
| A85013 |  | Panel Board Termination | 8d | 2019-08-06 | 2019-08-17 | A85008, A85009, A85011 | 123.5d | 25d | Electrical Crew [80 h] | 7.54 | MEP | 3 | MB |  |  |
| A84970 |  | Wiring devices Termination | 6d | 2019-09-04 | 2019-09-09 | A85005, A85006, A85010, A85012, A85007, A84967, 1F5-FNS-B05-1225 | 98.5d | 0d | Electrical Crew [60 h] | 5.66 | MEP | 3 | MB | 1617 | CON |
| A84969 |  | Lighting Fixtures Installation and Termination | 10d | 2019-09-10 | 2019-09-18 | A84966, A85004, A85013, A84970, 1F5-FNS-B05-1220, LOE-SUM3-190 FF | 98.5d | 84d | Electrical Crew [100 h] | 9.43 | MEP | 3 | MB | 1616 | CON |

| ID | WBS | Activity | Type | Duration | Start | Finish | Predecessors | Total float | Free float | Calendar | Resources | Cost | MSP Activity ID | Discipline | MEP-Phase | AREA | LOCATION |
| --- | --- | --- | --- | --- | --- | --- | --- | --- | --- | --- | --- | --- | --- | --- | --- | --- | --- |
|  | 1.4.1.4.1.1.4.1.4 | **FIRE FIGHTING SYSTEM** |  |  | 2019-05-09 | 2019-09-21 |  |  |  |  |  |  |  |  |  |  |  |
|  | 1.4.1.4.1.1.4.1.4.1. | **1st Fix** |  |  | 2019-05-09 | 2019-06-23 |  |  |  |  |  |  |  |  |  |  |  |
| A84979 |  | Fire Fighting Hangers & Supports |  | 15d | 2019-05-09 | 2019-05-22 | RM70 | 112.5d | 0d |  | Fire Fighting Crew [150 h] | 14.15 | 1622 | MEP | CON | 3 | MB |
| A84976 |  | Pipe Installation |  | 30d | 2019-05-23 | 2019-06-23 | A84979 | 112.5d | 0d |  | FF pipe [412 Limt]; FIRE FIGHTING [721 h] | 67.99 | 1625 | MEP | CON | 3 | MB |
|  | 1.4.1.4.1.1.4.1.4.-1 | **2nd Fix** |  |  | 2019-06-24 | 2019-07-21 |  |  |  |  |  |  |  |  |  |  |  |
| A84977 |  | Valve and Accessories Installation |  | 20d | 2019-06-24 | 2019-07-11 | A84976, A84979 | 112.5d | 0d |  | Fire Fighting Crew [200 h] | 18.86 | 1627 | MEP | CON | 3 | MB |
| A84978 |  | Leak Test |  | 10d | 2019-07-13 | 2019-07-21 | A84977 | 112.5d | 29d |  | Fire Fighting Crew [100 h] | 9.43 | 1631 | MEP | CON | 3 | MB |
|  | 1.4.1.4.1.1.4.1.4.-2 | **FF_Final Fix** |  |  | 2019-08-28 | 2019-09-21 |  |  |  |  |  |  |  |  |  |  |  |
| A84980 |  | Installation of Sprinklers |  | 15d | 2019-08-28 | 2019-09-11 | A84976, A84977, A84978, 1F5-FNS-B05-1220 | 107d | 0d |  | Fire Fighting Crew [150 h] | 14.15 | 1633 | MEP | CON | 3 | MB |
| A84981 |  | Instalaltion of Fire Extinguisher |  | 10d | 2019-09-11 | 2019-09-21 | A84976, A84980, A85014 FF, LOE-SUM3-190 FF | 162d | 162.5d |  | Fire Fighting Crew [100 h] | 9.43 |  | MEP | CON | 3 | MB |
| A85014 |  | Installation of Fire hose Cabinet |  | 5d | 2019-09-11 | 2019-09-16 | A84976, A84980 | 167d | 5d |  | Fire Fighting Crew [50 h] | 4.71 |  | MEP |  | 3 | MB |
|  | 1 | **NORTH MEZZAINE - ZONE 01 AND 02** |  |  | 2019-07-01 | 2019-11-27 |  |  |  |  |  |  |  |  |  |  |  |
| LOE-SUM3-200 |  | North . B05 - MEP Works; 1st & 2nd Fix | level of effort | 128d | 2019-07-01 | 2019-10-28 | RM80 | 35.25d | 0d | Saudi |  |  |  | MEP |  |  |  |
| LOE-SUM3-210 |  | North . B05 - MEP Works; Final fix | level of effort | 122.5d | 2019-08-05 | 2019-11-27 | LOE-SUM3-200, A85055 SS | 90.75d | 0d | Saudi |  |  |  | MEP |  |  |  |
|  | 4 | **B05 - MEZZAINE ZONE 01** |  |  | 2019-07-18 | 2019-11-27 |  |  |  |  |  |  |  |  |  |  |  |
|  | 1.4.1.4.1.1.4.1.1 | **HVAC SYSTEM** |  |  | 2019-07-18 | 2019-11-18 |  |  |  |  |  |  |  |  |  |  |  |
|  | 1.4.1.4.1.1.4.1.1.1. | **1st Fix** |  |  | 2019-07-18 | 2019-08-04 |  |  |  |  |  |  |  |  |  |  |  |
| A85083 |  | Hanger and support Installation - Duct |  | 6d | 2019-07-18 | 2019-07-23 | RM90 | 93.25d | 0d |  | Mechanical Crew [60 h] | 5.66 | 1546 | MEP | CON | 1 | MB |
| A85090 |  | Hanger and support Installation - CHW |  | 6d | 2019-07-18 | 2019-07-23 | A85083 SS | 93.25d | 0d |  | Mechanical Crew [60 h] | 5.66 |  | MEP |  | 1 | MB |
| A85081 |  | Duct Installation |  | 12d | 2019-07-20 | 2019-07-31 | A85083 SS+2d | 110.25d | 0d |  | Duct Installation [260 Sqmt]; HVAC [780 h] | 73.55 | 1549 | MEP | CON | 1 | MB |
| A85082 |  | Duct Insulation |  | 8d | 2019-07-23 | 2019-07-30 | A85081 SS+3d | 134.25d | 98.5d |  | Duct Insulation [263 Sqmt]; HVAC [190 h] | 17.92 | 1552 | MEP | CON | 1 | MB |
| A85092 |  | Chilled Water Piping Installation |  | 12d | 2019-07-23 | 2019-08-04 | A85090 | 93.25d | 0d |  | Mechanical Crew [120 h] | 11.32 |  | MEP |  | 1 | MB |
|  | 1.4.1.4.1.1.4.1.1.-1 | **2nd Fix** |  |  | 2019-07-31 | 2019-08-26 |  |  |  |  |  |  |  |  |  |  |  |
| A85091 |  | Installation of Duct Accessories (VD, FD, MSD etc....) |  | 12d | 2019-07-31 | 2019-08-14 | A85081 | 121.25d | 85.5d |  | Mechanical Crew [120 h] | 11.32 |  | MEP |  | 1 | MB |
| A85101 |  | CRAC Units Installation |  | 15d | 2019-07-31 | 2019-08-18 | A85081 | 110.25d | 9d |  | Mechanical Crew [150 h] | 14.15 |  | MEP |  | 1 | MB |
| A85102 |  | FCU Installation |  | 15d | 2019-07-31 | 2019-08-18 | A85081 | 110.25d | 9d |  | Mechanical Crew [150 h] | 14.15 |  | MEP |  | 1 | MB |
| A85103 |  | VRF DX Units Installation |  | 12d | 2019-07-31 | 2019-08-14 | A85081 | 113.25d | 12d |  | Mechanical Crew [120 h] | 11.32 |  | MEP |  | 1 | MB |
| A85104 |  | Installation of Attenuators |  | 10d | 2019-07-31 | 2019-08-13 | A85081 | 115.25d | 14d |  | Mechanical Crew [100 h] | 9.43 |  | MEP |  | 1 | MB |
| A85105 |  | Installation of HVAC Fans |  | 10d | 2019-07-31 | 2019-08-13 | A85081 | 115.25d | 14d |  | Mechanical Crew [100 h] | 9.43 |  | MEP |  | 1 | MB |
| A85107 |  | Pressurization Unit |  | 8d | 2019-07-31 | 2019-08-07 | A85081 | 117.25d | 16d |  | Mechanical Crew [80 h] | 7.54 |  | MEP |  | 1 | MB |
| A85108 |  | Dosing pot |  | 5d | 2019-07-31 | 2019-08-05 | A85081 | 120.25d | 19d |  | Mechanical Crew [50 h] | 4.71 |  | MEP |  | 1 | MB |
| A85110 |  | Air Handling Units Installation |  | 12d | 2019-07-31 | 2019-08-14 | A85081 | 113.25d | 12d |  | Mechanical Crew [120 h] | 11.32 |  | MEP |  | 1 | MB |
| A85094 |  | Valves and Accessories |  | 10d | 2019-08-04 | 2019-08-17 | A85092 | 93.25d | 0d |  | Mechanical Crew [100 h] | 9.43 |  | MEP |  | 1 | MB |
| A85106 |  | Air-Cooled Chillers |  | 15d | 2019-08-04 | 2019-08-21 | A85092 | 106.25d | 5d |  | Mechanical Crew [150 h] | 14.15 |  | MEP |  | 1 | MB |
| A85111 |  | Chilled Water Pump Installation |  | 12d | 2019-08-04 | 2019-08-18 | A85092 | 109.25d | 8d |  | Mechanical Crew [120 h] | 11.32 |  | MEP |  | 1 | MB |
| A85095 |  | Chilled Water Pipe Insulation and Cladding |  | 10d | 2019-08-17 | 2019-08-26 | A85092, A85094 | 93.25d | 0d |  | Mechanical Crew [100 h] | 9.43 |  | MEP |  | 1 | MB |

| ID | WBS | Activity | Duration | Start | Finish | Predecessors | Total float | Free float | Resources | Cost | Discipline | AREA | LOCATION | MSP Activity ID | MEP-Phase |
| --- | --- | --- | --- | --- | --- | --- | --- | --- | --- | --- | --- | --- | --- | --- | --- |
|  | 1.4.1.4.1.1.4.1.1.-2 | **HVAC_Final Fix** |  | 2019-08-26 | 2019-11-18 |  |  |  |  |  |  |  |  |  |  |
| A85109 |  | Equuipment Connection | 8d | 2019-08-26 | 2019-09-02 | A85111, A85110, A85106, A85105, A85104, A85101, A85102, A85103, A85108, A85107, A85095 | 101.25d | 65.5d | Mechanical Crew [80 h] | 7.54 | MEP | 1 | MB |  |  |
| A85093 |  | Air Outlets (Grills, Diffusers, Registers etc...) | 15d | 2019-11-04 | 2019-11-18 | A85091, A85081, A85082, A85109, 1F5-FNS-B05-3550 | 35.75d | 26.25d | Mechanical Crew [150 h] | 14.15 | MEP | 1 | MB |  |  |
|  | 1.4.1.4.1.1.4.1.2 | **PLUMBING SYSTEM** |  | 2019-07-18 | 2019-11-12 |  |  |  |  |  |  |  |  |  |  |
|  | 1.4.1.4.1.1.4.1.2.1. | **1st Fix** |  | 2019-07-18 | 2019-08-14 |  |  |  |  |  |  |  |  |  |  |
| A85069 |  | Hanger and support Installation | 10d | 2019-07-18 | 2019-07-27 | RM90 | 89.25d | 0d | Plumbing Crew [100 h] | 9.43 | MEP | 1 | MB | 1566 | CON |
| A85073 |  | Drainage and Vent Pipe & Fittings | 20d | 2019-07-23 | 2019-08-13 | A85069 SS+5d | 130.25d | 1d | Plumbing Crew [200 h] | 18.86 | MEP | 1 | MB | 1573 | CON |
| A85070 |  | Domestic Water Pipe & Fittings | 20d | 2019-07-23 | 2019-08-14 | A85069 SS+6d | 89.25d | 0d | Plumbing Crew [200 h] | 18.86 | MEP | 1 | MB | 1570 | CON |
|  | 1.4.1.4.1.1.4.1.2.-1 | **2nd Fix** |  | 2019-08-14 | 2019-08-29 |  |  |  |  |  |  |  |  |  |  |
| A85071 |  | Domestic Water Valves | 12d | 2019-08-14 | 2019-08-26 | A85070 | 89.25d | 0d | Plumbing Crew [120 h] | 11.32 | MEP | 1 | MB | 1571 | CON |
| A85097 |  | Sewege Pumps Installation | 5d | 2019-08-14 | 2019-08-19 | A85073, A85070 | 129.25d | 88d | Plumbing Crew [50 h] | 4.71 | MEP | 1 | MB |  |  |
| A85072 |  | Leak Test | 4d | 2019-08-26 | 2019-08-29 | A85071 | 89.25d | 62d | Plumbing Crew [40 h] | 3.77 | MEP | 1 | MB | 1572 | CON |
|  | 1.4.1.4.1.1.4.1.2.-2 | **PLM_Final Fix** |  | 2019-11-11 | 2019-11-12 |  |  |  |  |  |  |  |  |  |  |
| A85096 |  | Water Heaters | 2d | 2019-11-11 | 2019-11-12 | A85072, A85073, A85070, 1F5-FNS-B05-1350, 1F5-FNS-B05-3560 | 41.25d | 0d | Plumbing Crew [20 h] | 1.89 | MEP | 1 | MB |  |  |
| A85098 |  | Floor Drain | 2d | 2019-11-11 | 2019-11-12 | A85096 SS | 41.25d | 0d | Plumbing Crew [20 h] | 1.89 | MEP | 1 | MB |  |  |
| A85099 |  | Wash Basin / Water Closet | 2d | 2019-11-11 | 2019-11-12 | A85098 SS | 41.25d | 0d | Plumbing Crew [20 h] | 1.89 | MEP | 1 | MB |  |  |
| A85100 |  | Eye Wash | 2d | 2019-11-11 | 2019-11-12 | A85099 SS, A85097 | 41.25d | 18.75d | Plumbing Crew [20 h] | 1.89 | MEP | 1 | MB |  |  |
|  | 1.4.1.4.1.1.4.1.3 | **ELECTRICAL / CONTROLS** |  | 2019-07-18 | 2019-11-26 |  |  |  |  |  |  |  |  |  |  |
|  | 1.4.1.4.1.1.4.1.3.1. | **1st Fix** |  | 2019-07-18 | 2019-08-20 |  |  |  |  |  |  |  |  |  |  |
| A85079 |  | Installation of Conduits and Boxes | 12d | 2019-07-18 | 2019-07-29 | RM90 | 27.25d | 0d | Electrical Crew [120 h] | 11.32 | MEP | 1 | MB | 1592 | CON |
| A85080 |  | Installation of Cable Tray, Ladder and Trunk | 20d | 2019-07-29 | 2019-08-20 | A85079 | 94.25d | 0d | Electrical Crew [200 h] | 18.86 | MEP | 1 | MB | 1593 | CON |
|  | 1.4.1.4.1.1.4.1.3.-1 | **2nd Fix** |  | 2019-07-29 | 2019-10-28 |  |  |  |  |  |  |  |  |  |  |
| A85076 |  | Grounding and Bonding Installation | 20d | 2019-07-29 | 2019-08-20 | A85079 | 27.25d | 0d | Electrical Crew [200 h] | 18.86 | MEP | 1 | MB | 1596 | CON |
| A85112 |  | Wire Pulling | 20d | 2019-08-20 | 2019-09-08 | A85076 | 27.25d | 0d | Electrical Crew [200 h] | 18.86 | MEP | 1 | MB |  |  |
| A85118 |  | Installation of Bus Duct System | 20d | 2019-08-20 | 2019-09-08 | A85080 | 94.25d | 67d | Electrical Crew [200 h] | 18.86 | MEP | 1 | MB |  |  |
| A85074 |  | Power Cable Laying | 25d | 2019-09-08 | 2019-10-02 | A85112, A85076 | 27.25d | 0d | Electrical Crew [250 h] | 23.58 | MEP | 1 | MB | 1600 | CON |
| A85075 |  | Continuity Test - Power Cables | 4d | 2019-10-02 | 2019-10-06 | A85074 | 65.25d | 38d | Electrical Crew [40 h] | 3.77 | MEP | 1 | MB | 1601 | CON |
| A85113 |  | Installation of Central Battery Equipment | 6d | 2019-10-02 | 2019-10-08 | A85074, A85112 | 63.25d | 36d | Electrical Crew [60 h] | 5.66 | MEP | 1 | MB |  |  |
| A85114 |  | Installation of Disconnect Switch | 8d | 2019-10-02 | 2019-10-10 | A85074, A85112 | 61.25d | 34d | Electrical Crew [80 h] | 7.54 | MEP | 1 | MB |  |  |
| A85116 |  | Installation of Switch Boards (MDB, EMDB) | 15d | 2019-10-02 | 2019-10-16 | A85074, A85112 | 27.25d | 0d | Electrical Crew [150 h] | 14.15 | MEP | 1 | MB |  |  |
| A85117 |  | Installation of Panel Boards | 15d | 2019-10-02 | 2019-10-16 | A85074, A85112 | 27.25d | 0d | Electrical Crew [150 h] | 14.15 | MEP | 1 | MB |  |  |
| A85119 |  | Installation of MCC | 15d | 2019-10-02 | 2019-10-16 | A85074, A85112 | 27.25d | 0d | Electrical Crew [150 h] | 14.15 | MEP | 1 | MB |  |  |
| A85120 |  | Installation of Lighting Control System | 12d | 2019-10-02 | 2019-10-14 | A85074, A85112 | 30.25d | 3d | Electrical Crew [120 h] | 11.32 | MEP | 1 | MB |  |  |
| A85115 |  | Installation of Wiring Devices and Outlets | 12d | 2019-10-16 | 2019-10-28 | A85112, A85119, A85117, A85116, A85120 | 27.25d | 0d | Electrical Crew [120 h] | 11.32 | MEP | 1 | MB |  |  |

| ID | WBS | Activity | Duration | Start | Finish | Predecessors | Total float | Free float | Resources | Cost | Discipline | AREA | LOCATION | MSP Activity ID | MEP-Phase |
| --- | --- | --- | --- | --- | --- | --- | --- | --- | --- | --- | --- | --- | --- | --- | --- |
|  | 1.4.1.4.1.1.4.1.3.-2 | **Elec._Final Fix** |  | 2019-10-16 | 2019-11-26 |  |  |  |  |  |  |  |  |  |  |
| A85121 |  | Panel Board Termination | 8d | 2019-10-16 | 2019-10-24 | A85116, A85117, A85119 | 52.25d | 25d | Electrical Crew [80 h] | 7.54 | MEP | 1 | MB |  |  |
| A85078 |  | Wiring devices Termination | 6d | 2019-11-11 | 2019-11-17 | A85113, A85114, A85118, A85120, A85115, A85075, 1F5-FNS-B05-3560 | 27.25d | 0d | Electrical Crew [60 h] | 5.66 | MEP | 1 | MB | 1617 | CON |
| A85077 |  | Lighting Fixtures Installation and Termination | 10d | 2019-11-17 | 2019-11-26 | A85074, A85112, A85121, A85078, 1F5-FNS-B05-3550, LOE-SUM3-210 FF | 27.25d | 12.75d | Electrical Crew [100 h] | 9.43 | MEP | 1 | MB | 1616 | CON |
|  | 1.4.1.4.1.1.4.1.4 | **FIRE FIGHTING SYSTEM** |  | 2019-07-18 | 2019-11-27 |  |  |  |  |  |  |  |  |  |  |
|  | 1.4.1.4.1.1.4.1.4.1. | **1st Fix** |  | 2019-07-18 | 2019-09-01 |  |  |  |  |  |  |  |  |  |  |
| A85087 |  | Fire Fighting Hangers & Supports | 15d | 2019-07-18 | 2019-07-31 | RM90 | 56.25d | 0d | Fire Fighting Crew [150 h] | 14.15 | MEP | 1 | MB | 1622 | CON |
| A85084 |  | Pipe Installation | 30d | 2019-08-01 | 2019-09-01 | A85087 | 56.25d | 0d | FIRE FIGHTING [361 h]; FF pipe [206 Limt] | 34.04 | MEP | 1 | MB | 1625 | CON |
|  | 1.4.1.4.1.1.4.1.4.-1 | **2nd Fix** |  | 2019-09-02 | 2019-10-01 |  |  |  |  |  |  |  |  |  |  |
| A85085 |  | Valve and Accessories Installation | 20d | 2019-09-02 | 2019-09-19 | A85084, A85087 | 56.25d | 0d | Fire Fighting Crew [200 h] | 18.86 | MEP | 1 | MB | 1627 | CON |
| A85086 |  | Leak Test | 10d | 2019-09-21 | 2019-10-01 | A85085 | 56.25d | 29d | Fire Fighting Crew [100 h] | 9.43 | MEP | 1 | MB | 1631 | CON |
|  | 1.4.1.4.1.1.4.1.4.-2 | **FF_Final Fix** |  | 2019-11-04 | 2019-11-27 |  |  |  |  |  |  |  |  |  |  |
| A85088 |  | Installation of Sprinklers | 15d | 2019-11-04 | 2019-11-18 | A85084, A85085, A85086, 1F5-FNS-B05-3550 | 35.75d | 0d | Fire Fighting Crew [150 h] | 14.15 | MEP | 1 | MB | 1633 | CON |
| A85089 |  | Instalaltion of Fire Extinguisher | 10d | 2019-11-18 | 2019-11-27 | A85084, A85088, A85122 FF, LOE-SUM3-210 FF | 90.75d | 91.25d | Fire Fighting Crew [100 h] | 9.43 | MEP | 1 | MB |  | CON |
| A85122 |  | Installation of Fire hose Cabinet | 5d | 2019-11-18 | 2019-11-23 | A85084, A85088 | 95.75d | 5d | Fire Fighting Crew [50 h] | 4.71 | MEP | 1 | MB |  |  |
|  | 5 | **B05 - MEZZAINE ZONE 02** |  | 2019-07-01 | 2019-11-10 |  |  |  |  |  |  |  |  |  |  |
|  | 1.4.1.4.1.1.4.1.1 | **HVAC SYSTEM** |  | 2019-07-01 | 2019-10-31 |  |  |  |  |  |  |  |  |  |  |
|  | 1.4.1.4.1.1.4.1.1.1. | **1st Fix** |  | 2019-07-01 | 2019-07-17 |  |  |  |  |  |  |  |  |  |  |
| A85029 |  | Hanger and support Installation - Duct | 6d | 2019-07-01 | 2019-07-06 | RM80 | 104.5d | 0d | Mechanical Crew [60 h] | 5.66 | MEP | 2 | MB | 1546 | CON |
| A85036 |  | Hanger and support Installation - CHW | 6d | 2019-07-01 | 2019-07-06 | A85029 SS | 104.5d | 0d | Mechanical Crew [60 h] | 5.66 | MEP | 2 | MB |  |  |
| A85027 |  | Duct Installation | 12d | 2019-07-02 | 2019-07-14 | A85029 SS+2d | 129d | 0d | Duct Installation [260 Sqmt]; HVAC [780 h] | 73.55 | MEP | 2 | MB | 1549 | CON |
| A85028 |  | Duct Insulation | 8d | 2019-07-06 | 2019-07-13 | A85027 SS+3d | 153d | 98.5d | Duct Insulation [263 Sqmt]; HVAC [190 h] | 17.92 | MEP | 2 | MB | 1552 | CON |
| A85038 |  | Chilled Water Piping Installation | 12d | 2019-07-06 | 2019-07-17 | A85036 | 104.5d | 0d | Mechanical Crew [120 h] | 11.32 | MEP | 2 | MB |  |  |
|  | 1.4.1.4.1.1.4.1.1.-1 | **2nd Fix** |  | 2019-07-14 | 2019-08-05 |  |  |  |  |  |  |  |  |  |  |
| A85037 |  | Installation of Duct Accessories (VD, FD, MSD etc....) | 12d | 2019-07-14 | 2019-07-24 | A85027 | 140d | 85.5d | Mechanical Crew [120 h] | 11.32 | MEP | 2 | MB |  |  |
| A85047 |  | CRAC Units Installation | 15d | 2019-07-14 | 2019-07-28 | A85027 | 129d | 9d | Mechanical Crew [150 h] | 14.15 | MEP | 2 | MB |  |  |
| A85048 |  | FCU Installation | 15d | 2019-07-14 | 2019-07-28 | A85027 | 129d | 9d | Mechanical Crew [150 h] | 14.15 | MEP | 2 | MB |  |  |
| A85049 |  | VRF DX Units Installation | 12d | 2019-07-14 | 2019-07-24 | A85027 | 132d | 12d | Mechanical Crew [120 h] | 11.32 | MEP | 2 | MB |  |  |
| A85050 |  | Installation of Attenuators | 10d | 2019-07-14 | 2019-07-23 | A85027 | 134d | 14d | Mechanical Crew [100 h] | 9.43 | MEP | 2 | MB |  |  |
| A85051 |  | Installation of HVAC Fans | 10d | 2019-07-14 | 2019-07-23 | A85027 | 134d | 14d | Mechanical Crew [100 h] | 9.43 | MEP | 2 | MB |  |  |
| A85053 |  | Pressurization Unit | 8d | 2019-07-14 | 2019-07-21 | A85027 | 136d | 16d | Mechanical Crew [80 h] | 7.54 | MEP | 2 | MB |  |  |
| A85054 |  | Dosing pot | 5d | 2019-07-14 | 2019-07-18 | A85027 | 139d | 19d | Mechanical Crew [50 h] | 4.71 | MEP | 2 | MB |  |  |
| A85056 |  | Air Handling Units Installation | 12d | 2019-07-14 | 2019-07-24 | A85027 | 132d | 12d | Mechanical Crew [120 h] | 11.32 | MEP | 2 | MB |  |  |
| A85040 |  | Valves and Accessories | 10d | 2019-07-17 | 2019-07-27 | A85038 | 104.5d | 0d | Mechanical Crew [100 h] | 9.43 | MEP | 2 | MB |  |  |
| A85052 |  | Air-Cooled Chillers | 15d | 2019-07-17 | 2019-07-31 | A85038 | 125d | 5d | Mechanical Crew [150 h] | 14.15 | MEP | 2 | MB |  |  |
| A85057 |  | Chilled Water Pump Installation | 12d | 2019-07-17 | 2019-07-28 | A85038 | 128d | 8d | Mechanical Crew [120 h] | 11.32 | MEP | 2 | MB |  |  |
| A85041 |  | Chilled Water Pipe Insulation and Cladding | 10d | 2019-07-27 | 2019-08-05 | A85038, A85040 | 104.5d | 0d | Mechanical Crew [100 h] | 9.43 | MEP | 2 | MB |  |  |

| ID | WBS | Activity | Duration | Start | Finish | Predecessors | Total float | Free float | Resources | Cost | Discipline | AREA | LOCATION | MSP Activity ID | MEP-Phase |
| --- | --- | --- | --- | --- | --- | --- | --- | --- | --- | --- | --- | --- | --- | --- | --- |
|  | 1.4.1.4.1.1.4.1.1.-2 | **HVAC_Final Fix** |  | 2019-08-05 | 2019-10-31 |  |  |  |  |  |  |  |  |  |  |
| A85055 |  | Equuipment Connection | 8d | 2019-08-05 | 2019-08-15 | A85057, A85056, A85052, A85051, A85050, A85047, A85048, A85049, A85054, A85053, A85041 | 120d | 65.5d | Mechanical Crew [80 h] | 7.54 | MEP | 2 | MB |  |  |
| A85039 |  | Air Outlets (Grills, Diffusers, Registers etc...) | 15d | 2019-10-17 | 2019-10-31 | A85037, A85027, A85028, A85055, 1F5-FNS-B05-1340 | 54.5d | 45d | Mechanical Crew [150 h] | 14.15 | MEP | 2 | MB |  |  |
|  | 1.4.1.4.1.1.4.1.2 | **PLUMBING SYSTEM** |  | 2019-07-01 | 2019-10-26 |  |  |  |  |  |  |  |  |  |  |
|  | 1.4.1.4.1.1.4.1.2.1. | **1st Fix** |  | 2019-07-01 | 2019-07-24 |  |  |  |  |  |  |  |  |  |  |
| A85015 |  | Hanger and support Installation | 10d | 2019-07-01 | 2019-07-09 | RM80 | 100.5d | 0d | Plumbing Crew [100 h] | 9.43 | MEP | 2 | MB | 1566 | CON |
| A85019 |  | Drainage and Vent Pipe & Fittings | 20d | 2019-07-06 | 2019-07-23 | A85015 SS+5d | 149d | 1d | Plumbing Crew [200 h] | 18.86 | MEP | 2 | MB | 1573 | CON |
| A85016 |  | Domestic Water Pipe & Fittings | 20d | 2019-07-06 | 2019-07-24 | A85015 SS+6d | 100.5d | 0d | Plumbing Crew [200 h] | 18.86 | MEP | 2 | MB | 1570 | CON |
|  | 1.4.1.4.1.1.4.1.2.-1 | **2nd Fix** |  | 2019-07-24 | 2019-08-08 |  |  |  |  |  |  |  |  |  |  |
| A85017 |  | Domestic Water Valves | 12d | 2019-07-24 | 2019-08-05 | A85016 | 100.5d | 0d | Plumbing Crew [120 h] | 11.32 | MEP | 2 | MB | 1571 | CON |
| A85043 |  | Sewege Pumps Installation | 5d | 2019-07-24 | 2019-07-29 | A85019, A85016 | 148d | 88d | Plumbing Crew [50 h] | 4.71 | MEP | 2 | MB |  |  |
| A85018 |  | Leak Test | 4d | 2019-08-05 | 2019-08-08 | A85017 | 100.5d | 62d | Plumbing Crew [40 h] | 3.77 | MEP | 2 | MB | 1572 | CON |
|  | 1.4.1.4.1.1.4.1.2.-2 | **PLM_Final Fix** |  | 2019-10-24 | 2019-10-26 |  |  |  |  |  |  |  |  |  |  |
| A85042 |  | Water Heaters | 2d | 2019-10-24 | 2019-10-26 | A85018, A85019, A85016, 1F5-FNS-B05-1350 | 60d | 0d | Plumbing Crew [20 h] | 1.89 | MEP | 2 | MB |  |  |
| A85044 |  | Floor Drain | 2d | 2019-10-24 | 2019-10-26 | A85042 SS | 60d | 0d | Plumbing Crew [20 h] | 1.89 | MEP | 2 | MB |  |  |
| A85045 |  | Wash Basin / Water Closet | 2d | 2019-10-24 | 2019-10-26 | A85044 SS | 60d | 0d | Plumbing Crew [20 h] | 1.89 | MEP | 2 | MB |  |  |
| A85046 |  | Eye Wash | 2d | 2019-10-24 | 2019-10-26 | A85045 SS, A85043 | 60d | 37.5d | Plumbing Crew [20 h] | 1.89 | MEP | 2 | MB |  |  |
|  | 1.4.1.4.1.1.4.1.3 | **ELECTRICAL / CONTROLS** |  | 2019-07-01 | 2019-11-09 |  |  |  |  |  |  |  |  |  |  |
|  | 1.4.1.4.1.1.4.1.3.1. | **1st Fix** |  | 2019-07-01 | 2019-07-30 |  |  |  |  |  |  |  |  |  |  |
| A85025 |  | Installation of Conduits and Boxes | 12d | 2019-07-01 | 2019-07-11 | RM80 | 38.5d | 0d | Electrical Crew [120 h] | 11.32 | MEP | 2 | MB | 1592 | CON |
| A85026 |  | Installation of Cable Tray, Ladder and Trunk | 20d | 2019-07-11 | 2019-07-30 | A85025 | 113d | 0d | Electrical Crew [200 h] | 18.86 | MEP | 2 | MB | 1593 | CON |
|  | 1.4.1.4.1.1.4.1.3.-1 | **2nd Fix** |  | 2019-07-11 | 2019-10-10 |  |  |  |  |  |  |  |  |  |  |
| A85022 |  | Grounding and Bonding Installation | 20d | 2019-07-11 | 2019-07-30 | A85025 | 38.5d | 0d | Electrical Crew [200 h] | 18.86 | MEP | 2 | MB | 1596 | CON |
| A85058 |  | Wire Pulling | 20d | 2019-07-30 | 2019-08-21 | A85022 | 38.5d | 0d | Electrical Crew [200 h] | 18.86 | MEP | 2 | MB |  |  |
| A85064 |  | Installation of Bus Duct System | 20d | 2019-07-30 | 2019-08-21 | A85026 | 113d | 67d | Electrical Crew [200 h] | 18.86 | MEP | 2 | MB |  |  |
| A85020 |  | Power Cable Laying | 25d | 2019-08-21 | 2019-09-14 | A85058, A85022 | 38.5d | 0d | Electrical Crew [250 h] | 23.58 | MEP | 2 | MB | 1600 | CON |
| A85021 |  | Continuity Test - Power Cables | 4d | 2019-09-14 | 2019-09-17 | A85020 | 84d | 38d | Electrical Crew [40 h] | 3.77 | MEP | 2 | MB | 1601 | CON |
| A85059 |  | Installation of Central Battery Equipment | 6d | 2019-09-14 | 2019-09-19 | A85020, A85058 | 82d | 36d | Electrical Crew [60 h] | 5.66 | MEP | 2 | MB |  |  |
| A85060 |  | Installation of Disconnect Switch | 8d | 2019-09-14 | 2019-09-21 | A85020, A85058 | 80d | 34d | Electrical Crew [80 h] | 7.54 | MEP | 2 | MB |  |  |
| A85062 |  | Installation of Switch Boards (MDB, EMDB) | 15d | 2019-09-14 | 2019-09-29 | A85020, A85058 | 38.5d | 0d | Electrical Crew [150 h] | 14.15 | MEP | 2 | MB |  |  |
| A85063 |  | Installation of Panel Boards | 15d | 2019-09-14 | 2019-09-29 | A85020, A85058 | 38.5d | 0d | Electrical Crew [150 h] | 14.15 | MEP | 2 | MB |  |  |
| A85065 |  | Installation of MCC | 15d | 2019-09-14 | 2019-09-29 | A85020, A85058 | 38.5d | 0d | Electrical Crew [150 h] | 14.15 | MEP | 2 | MB |  |  |
| A85066 |  | Installation of Lighting Control System | 12d | 2019-09-14 | 2019-09-26 | A85020, A85058 | 41.5d | 3d | Electrical Crew [120 h] | 11.32 | MEP | 2 | MB |  |  |
| A85061 |  | Installation of Wiring Devices and Outlets | 12d | 2019-09-29 | 2019-10-10 | A85058, A85065, A85063, A85062, A85066 | 38.5d | 0d | Electrical Crew [120 h] | 11.32 | MEP | 2 | MB |  |  |

| ID | WBS | Activity | Type | Duration | Start | Finish | Predecessors | Total float | Free float | Calendar | Resources | Cost | Discipline | AREA | LOCATION | MSP Activity ID | MEP-Phase |
| --- | --- | --- | --- | --- | --- | --- | --- | --- | --- | --- | --- | --- | --- | --- | --- | --- | --- |
|  | 1.4.1.4.1.1.4.1.3.-2 | **Elec._Final Fix** |  |  | 2019-09-29 | 2019-11-09 |  |  |  |  |  |  |  |  |  |  |  |
| A85067 |  | Panel Board Termination |  | 8d | 2019-09-29 | 2019-10-07 | A85062, A85063, A85065 | 71d | 25d |  | Electrical Crew [80 h] | 7.54 | MEP | 2 | MB |  |  |
| A85024 |  | Wiring devices Termination |  | 6d | 2019-10-24 | 2019-10-30 | A85059, A85060, A85064, A85066, A85061, A85021, 1F5-FNS-B05-1350 | 46d | 0d |  | Electrical Crew [60 h] | 5.66 | MEP | 2 | MB | 1617 | CON |
| A85023 |  | Lighting Fixtures Installation and Termination |  | 10d | 2019-10-30 | 2019-11-09 | A85020, A85058, A85067, A85024, 1F5-FNS-B05-1340 | 46d | 31.5d |  | Electrical Crew [100 h] | 9.43 | MEP | 2 | MB | 1616 | CON |
|  | 1.4.1.4.1.1.4.1.4 | **FIRE FIGHTING SYSTEM** |  |  | 2019-07-01 | 2019-11-10 |  |  |  |  |  |  |  |  |  |  |  |
|  | 1.4.1.4.1.1.4.1.4.1. | **1st Fix** |  |  | 2019-07-01 | 2019-08-14 |  |  |  |  |  |  |  |  |  |  |  |
| A85033 |  | Fire Fighting Hangers & Supports |  | 15d | 2019-07-01 | 2019-07-14 | RM80 | 67.5d | 0d |  | Fire Fighting Crew [150 h] | 14.15 | MEP | 2 | MB | 1622 | CON |
| A85030 |  | Pipe Installation |  | 30d | 2019-07-15 | 2019-08-14 | A85033 | 67.5d | 0d |  | FF pipe [206 Limt]; FIRE FIGHTING [361 h] | 34.04 | MEP | 2 | MB | 1625 | CON |
|  | 1.4.1.4.1.1.4.1.4.-1 | **2nd Fix** |  |  | 2019-08-15 | 2019-09-11 |  |  |  |  |  |  |  |  |  |  |  |
| A85031 |  | Valve and Accessories Installation |  | 20d | 2019-08-15 | 2019-09-02 | A85030, A85033 | 67.5d | 0d |  | Fire Fighting Crew [200 h] | 18.86 | MEP | 2 | MB | 1627 | CON |
| A85032 |  | Leak Test |  | 10d | 2019-09-03 | 2019-09-11 | A85031 | 67.5d | 29d |  | Fire Fighting Crew [100 h] | 9.43 | MEP | 2 | MB | 1631 | CON |
|  | 1.4.1.4.1.1.4.1.4.-2 | **FF_Final Fix** |  |  | 2019-10-17 | 2019-11-10 |  |  |  |  |  |  |  |  |  |  |  |
| A85034 |  | Installation of Sprinklers |  | 15d | 2019-10-17 | 2019-10-31 | A85030, A85031, A85032, 1F5-FNS-B05-1340 | 54.5d | 0d |  | Fire Fighting Crew [150 h] | 14.15 | MEP | 2 | MB | 1633 | CON |
| A85035 |  | Instalaltion of Fire Extinguisher |  | 10d | 2019-10-31 | 2019-11-10 | A85030, A85034, A85068 FF | 109.5d | 110d |  | Fire Fighting Crew [100 h] | 9.43 | MEP | 2 | MB |  | CON |
| A85068 |  | Installation of Fire hose Cabinet |  | 5d | 2019-10-31 | 2019-11-05 | A85030, A85034 | 114.5d | 5d |  | Fire Fighting Crew [50 h] | 4.71 | MEP | 2 | MB |  |  |
|  | 1.4.3 | **B04 - TECHINICAL** |  |  | 2019-04-17 | 2019-11-14 |  |  |  |  |  |  |  |  |  |  |  |
|  | 7 | **SOUTH TECHINICAL - ZONE 4 AND 5** |  |  | 2019-04-17 | 2019-09-15 |  |  |  |  |  |  |  |  |  |  |  |
| LOE-SUM3-220 |  | South . B04 - MEP Works; 1st & 2nd Fix | level of effort | 129d | 2019-04-17 | 2019-08-15 | RM110 | 114.25d | 0d | Saudi |  |  | MEP |  |  |  |  |
| LOE-SUM3-230 |  | South . B04 - MEP Works; Final fix | level of effort | 123.5d | 2019-05-22 | 2019-09-15 | LOE-SUM3-220, A45842 SS | 169.75d | 0d | Saudi |  |  | MEP |  |  |  |  |
|  | 1 | **B04 - TECHINICAL ZONE 04** |  |  | 2019-05-04 | 2019-09-15 |  |  |  |  |  |  |  |  |  |  |  |
|  | 1.4.1.4.1.1.4.1.1 | **HVAC SYSTEM** |  |  | 2019-05-04 | 2019-09-05 |  |  |  |  |  |  |  |  |  |  |  |
|  | 1.4.1.4.1.1.4.1.1.1. | **1st Fix** |  |  | 2019-05-04 | 2019-05-20 |  |  |  |  |  |  |  |  |  |  |  |
| A43422 |  | Hanger and support Installation - Duct |  | 6d | 2019-05-04 | 2019-05-08 | RM100 | 162.25d | 0d |  | Mechanical Crew [60 h] | 5.66 | MEP | 4 | MB | 1546 | CON |
| A43492 |  | Hanger and support Installation - CHW |  | 6d | 2019-05-04 | 2019-05-08 | A43422 SS | 162.25d | 0d |  | Mechanical Crew [60 h] | 5.66 | MEP | 4 | MB |  |  |
| A43402 |  | Duct Installation |  | 12d | 2019-05-05 | 2019-05-16 | A43422 SS+2d | 187.75d | 0d |  | Duct Installation [260 Sqmt]; HVAC [780 h] | 73.55 | MEP | 4 | MB | 1549 | CON |
| A43412 |  | Duct Insulation |  | 8d | 2019-05-08 | 2019-05-15 | A43402 SS+3d | 211.75d | 98.5d |  | Duct Insulation [262 Sqmt]; HVAC [190 h] | 17.92 | MEP | 4 | MB | 1552 | CON |
| A43512 |  | Chilled Water Piping Installation |  | 12d | 2019-05-08 | 2019-05-20 | A43492 | 162.25d | 0d |  | Mechanical Crew [120 h] | 11.32 | MEP | 4 | MB |  |  |

| ID | WBS | Activity | Duration | Start | Finish | Predecessors | Total float | Free float | Resources | Cost | Discipline | AREA | LOCATION | MSP Activity ID | MEP-Phase |
| --- | --- | --- | --- | --- | --- | --- | --- | --- | --- | --- | --- | --- | --- | --- | --- |
|  | 1.4.1.4.1.1.4.1.1.-1 | **2nd Fix** |  | 2019-05-16 | 2019-06-11 |  |  |  |  |  |  |  |  |  |  |
| A43502 |  | Installation of Duct Accessories (VD, FD, MSD etc....) | 12d | 2019-05-16 | 2019-05-27 | A43402 | 198.75d | 85.5d | Mechanical Crew [120 h] | 11.32 | MEP | 4 | MB |  |  |
| A43602 |  | CRAC Units Installation | 15d | 2019-05-16 | 2019-05-30 | A43402 | 187.75d | 9d | Mechanical Crew [150 h] | 14.15 | MEP | 4 | MB |  |  |
| A43612 |  | FCU Installation | 15d | 2019-05-16 | 2019-05-30 | A43402 | 187.75d | 9d | Mechanical Crew [150 h] | 14.15 | MEP | 4 | MB |  |  |
| A43622 |  | VRF DX Units Installation | 12d | 2019-05-16 | 2019-05-27 | A43402 | 190.75d | 12d | Mechanical Crew [120 h] | 11.32 | MEP | 4 | MB |  |  |
| A43632 |  | Installation of Attenuators | 10d | 2019-05-16 | 2019-05-26 | A43402 | 192.75d | 14d | Mechanical Crew [100 h] | 9.43 | MEP | 4 | MB |  |  |
| A43642 |  | Installation of HVAC Fans | 10d | 2019-05-16 | 2019-05-26 | A43402 | 192.75d | 14d | Mechanical Crew [100 h] | 9.43 | MEP | 4 | MB |  |  |
| A43662 |  | Pressurization Unit | 8d | 2019-05-16 | 2019-05-23 | A43402 | 194.75d | 16d | Mechanical Crew [80 h] | 7.54 | MEP | 4 | MB |  |  |
| A43672 |  | Dosing pot | 5d | 2019-05-16 | 2019-05-21 | A43402 | 197.75d | 19d | Mechanical Crew [50 h] | 4.71 | MEP | 4 | MB |  |  |
| A43692 |  | Air Handling Units Installation | 12d | 2019-05-16 | 2019-05-27 | A43402 | 190.75d | 12d | Mechanical Crew [120 h] | 11.32 | MEP | 4 | MB |  |  |
| A43532 |  | Valves and Accessories | 10d | 2019-05-20 | 2019-05-29 | A43512 | 162.25d | 0d | Mechanical Crew [100 h] | 9.43 | MEP | 4 | MB |  |  |
| A43652 |  | Air-Cooled Chillers | 15d | 2019-05-20 | 2019-06-03 | A43512 | 183.75d | 5d | Mechanical Crew [150 h] | 14.15 | MEP | 4 | MB |  |  |
| A43702 |  | Chilled Water Pump Installation | 12d | 2019-05-20 | 2019-05-30 | A43512 | 186.75d | 8d | Mechanical Crew [120 h] | 11.32 | MEP | 4 | MB |  |  |
| A43542 |  | Chilled Water Pipe Insulation and Cladding | 10d | 2019-05-29 | 2019-06-11 | A43512, A43532 | 162.25d | 0d | Mechanical Crew [100 h] | 9.43 | MEP | 4 | MB |  |  |
|  | 1.4.1.4.1.1.4.1.1.-2 | **HVAC_Final Fix** |  | 2019-06-11 | 2019-09-05 |  |  |  |  |  |  |  |  |  |  |
| A43682 |  | Equuipment Connection | 8d | 2019-06-11 | 2019-06-18 | A43702, A43692, A43652, A43642, A43632, A43602, A43612, A43622, A43672, A43662, A43542 | 178.75d | 65.5d | Mechanical Crew [80 h] | 7.54 | MEP | 4 | MB |  |  |
| A43522 |  | Air Outlets (Grills, Diffusers, Registers etc...) | 15d | 2019-08-22 | 2019-09-05 | A43502, A43402, A43412, A43682, 1F5-FNS-B04-180, 1F5-FNS-B04-410 | 113.25d | 103.75d | Mechanical Crew [150 h] | 14.15 | MEP | 4 | MB |  |  |
|  | 1.4.1.4.1.1.4.1.2 | **PLUMBING SYSTEM** |  | 2019-05-04 | 2019-08-31 |  |  |  |  |  |  |  |  |  |  |
|  | 1.4.1.4.1.1.4.1.2.1. | **1st Fix** |  | 2019-05-04 | 2019-05-27 |  |  |  |  |  |  |  |  |  |  |
| A43282 |  | Hanger and support Installation | 10d | 2019-05-04 | 2019-05-12 | RM100 | 158.25d | 0d | Plumbing Crew [100 h] | 9.43 | MEP | 4 | MB | 1566 | CON |
| A43322 |  | Drainage and Vent Pipe & Fittings | 20d | 2019-05-08 | 2019-05-26 | A43282 SS+5d | 207.75d | 1d | Plumbing Crew [200 h] | 18.86 | MEP | 4 | MB | 1573 | CON |
| A43292 |  | Domestic Water Pipe & Fittings | 20d | 2019-05-08 | 2019-05-27 | A43282 SS+6d | 158.25d | 0d | Plumbing Crew [200 h] | 18.86 | MEP | 4 | MB | 1570 | CON |
|  | 1.4.1.4.1.1.4.1.2.-1 | **2nd Fix** |  | 2019-05-27 | 2019-06-15 |  |  |  |  |  |  |  |  |  |  |
| A43302 |  | Domestic Water Valves | 12d | 2019-05-27 | 2019-06-11 | A43292 | 158.25d | 0d | Plumbing Crew [120 h] | 11.32 | MEP | 4 | MB | 1571 | CON |
| A43562 |  | Sewege Pumps Installation | 5d | 2019-05-27 | 2019-06-01 | A43322, A43292 | 206.75d | 88d | Plumbing Crew [50 h] | 4.71 | MEP | 4 | MB |  |  |
| A43312 |  | Leak Test | 4d | 2019-06-11 | 2019-06-15 | A43302 | 158.25d | 62d | Plumbing Crew [40 h] | 3.77 | MEP | 4 | MB | 1572 | CON |

| ID | WBS | Activity | Duration | Start | Finish | Predecessors | Total float | Free float | Resources | Cost | Discipline | AREA | LOCATION | MSP Activity ID | MEP-Phase |
| --- | --- | --- | --- | --- | --- | --- | --- | --- | --- | --- | --- | --- | --- | --- | --- |
|  | 1.4.1.4.1.1.4.1.2.-2 | **PLM_Final Fix** |  | 2019-08-29 | 2019-08-31 |  |  |  |  |  |  |  |  |  |  |
| A43552 |  | Water Heaters | 2d | 2019-08-29 | 2019-08-31 | A43312, A43322, A43292, 1F5-FNS-B04-415 | 118.75d | 0d | Plumbing Crew [20 h] | 1.89 | MEP | 4 | MB |  |  |
| A43572 |  | Floor Drain | 2d | 2019-08-29 | 2019-08-31 | A43552 SS | 118.75d | 0d | Plumbing Crew [20 h] | 1.89 | MEP | 4 | MB |  |  |
| A43582 |  | Wash Basin / Water Closet | 2d | 2019-08-29 | 2019-08-31 | A43572 SS | 118.75d | 0d | Plumbing Crew [20 h] | 1.89 | MEP | 4 | MB |  |  |
| A43592 |  | Eye Wash | 2d | 2019-08-29 | 2019-08-31 | A43582 SS, A43562 | 118.75d | 96.25d | Plumbing Crew [20 h] | 1.89 | MEP | 4 | MB |  |  |
|  | 1.4.1.4.1.1.4.1.3 | **ELECTRICAL / CONTROLS** |  | 2019-05-04 | 2019-09-01 |  |  |  |  |  |  |  |  |  |  |
|  | 1.4.1.4.1.1.4.1.3.1. | **1st Fix** |  | 2019-05-04 | 2019-06-02 |  |  |  |  |  |  |  |  |  |  |
| A43382 |  | Installation of Conduits and Boxes | 12d | 2019-05-04 | 2019-05-14 | RM100 | 96.25d | 0d | Electrical Crew [120 h] | 11.32 | MEP | 4 | MB | 1592 | CON |
| A43392 |  | Installation of Cable Tray, Ladder and Trunk | 20d | 2019-05-14 | 2019-06-02 | A43382 | 171.75d | 0d | Electrical Crew [200 h] | 18.86 | MEP | 4 | MB | 1593 | CON |
|  | 1.4.1.4.1.1.4.1.3.-1 | **2nd Fix** |  | 2019-05-14 | 2019-08-15 |  |  |  |  |  |  |  |  |  |  |
| A43352 |  | Grounding and Bonding Installation | 20d | 2019-05-14 | 2019-06-02 | A43382 | 96.25d | 0d | Electrical Crew [200 h] | 18.86 | MEP | 4 | MB | 1596 | CON |
| A43712 |  | Wire Pulling | 20d | 2019-06-02 | 2019-06-24 | A43352 | 96.25d | 0d | Electrical Crew [200 h] | 18.86 | MEP | 4 | MB |  |  |
| A43772 |  | Installation of Bus Duct System | 20d | 2019-06-02 | 2019-06-24 | A43392 | 171.75d | 52d | Electrical Crew [200 h] | 18.86 | MEP | 4 | MB |  |  |
| A43332 |  | Power Cable Laying | 25d | 2019-06-24 | 2019-07-17 | A43712, A43352 | 96.25d | 0d | Electrical Crew [250 h] | 23.58 | MEP | 4 | MB | 1600 | CON |
| A43342 |  | Continuity Test - Power Cables | 4d | 2019-07-17 | 2019-07-21 | A43332 | 142.75d | 23d | Electrical Crew [40 h] | 3.77 | MEP | 4 | MB | 1601 | CON |
| A43722 |  | Installation of Central Battery Equipment | 6d | 2019-07-17 | 2019-07-23 | A43332, A43712 | 140.75d | 21d | Electrical Crew [60 h] | 5.66 | MEP | 4 | MB |  |  |
| A43732 |  | Installation of Disconnect Switch | 8d | 2019-07-17 | 2019-07-24 | A43332, A43712 | 138.75d | 19d | Electrical Crew [80 h] | 7.54 | MEP | 4 | MB |  |  |
| A43752 |  | Installation of Switch Boards (MDB, EMDB) | 15d | 2019-07-17 | 2019-07-31 | A43332, A43712 | 96.25d | 0d | Electrical Crew [150 h] | 14.15 | MEP | 4 | MB |  |  |
| A43762 |  | Installation of Panel Boards | 15d | 2019-07-17 | 2019-07-31 | A43332, A43712 | 96.25d | 0d | Electrical Crew [150 h] | 14.15 | MEP | 4 | MB |  |  |
| A43782 |  | Installation of MCC | 15d | 2019-07-17 | 2019-07-31 | A43332, A43712 | 96.25d | 0d | Electrical Crew [150 h] | 14.15 | MEP | 4 | MB |  |  |
| A43792 |  | Installation of Lighting Control System | 12d | 2019-07-17 | 2019-07-29 | A43332, A43712 | 99.25d | 3d | Electrical Crew [120 h] | 11.32 | MEP | 4 | MB |  |  |
| A43742 |  | Installation of Wiring Devices and Outlets | 12d | 2019-07-31 | 2019-08-15 | A43712, A43782, A43762, A43752, A43792 | 96.25d | 0d | Electrical Crew [120 h] | 11.32 | MEP | 4 | MB |  |  |
|  | 1.4.1.4.1.1.4.1.3.-2 | **Elec._Final Fix** |  | 2019-07-31 | 2019-09-01 |  |  |  |  |  |  |  |  |  |  |
| A43802 |  | Panel Board Termination | 8d | 2019-07-31 | 2019-08-07 | A43752, A43762, A43782 | 129.75d | 11.5d | Electrical Crew [80 h] | 7.54 | MEP | 4 | MB |  |  |
| A43372 |  | Wiring devices Termination | 6d | 2019-08-15 | 2019-08-20 | A43722, A43732, A43772, A43792, A43742, A43342 | 119.75d | 1.5d | Electrical Crew [60 h] | 5.66 | MEP | 4 | MB | 1617 | CON |
| A43362 |  | Lighting Fixtures Installation and Termination | 10d | 2019-08-22 | 2019-09-01 | A43332, A43712, A43802, A43372, 1F5-FNS-B04-180, 1F5-FNS-B04-410 | 118.25d | 103.75d | Electrical Crew [100 h] | 9.43 | MEP | 4 | MB | 1616 | CON |

| ID | WBS | Activity | Duration | Start | Finish | Predecessors | Total float | Free float | Resources | Cost | MSP Activity ID | Discipline | MEP-Phase | AREA | LOCATION |
| --- | --- | --- | --- | --- | --- | --- | --- | --- | --- | --- | --- | --- | --- | --- | --- |
|  | 1.4.1.4.1.1.4.1.4 | **FIRE FIGHTING SYSTEM** |  | 2019-05-04 | 2019-09-15 |  |  |  |  |  |  |  |  |  |  |
|  | 1.4.1.4.1.1.4.1.4.1. | **1st Fix** |  | 2019-05-04 | 2019-06-17 |  |  |  |  |  |  |  |  |  |  |
| A43462 |  | Fire Fighting Hangers & Supports | 15d | 2019-05-04 | 2019-05-16 | RM100 | 125.25d | 0d | Fire Fighting Crew [150 h] | 14.15 | 1622 | MEP | CON | 4 | MB |
| A43432 |  | Pipe Installation | 30d | 2019-05-18 | 2019-06-17 | A43462 | 125.25d | 0d | FIRE FIGHTING [361 h]; FF pipe [206 Limt] | 34.04 | 1625 | MEP | CON | 4 | MB |
|  | 1.4.1.4.1.1.4.1.4.-1 | **2nd Fix** |  | 2019-06-18 | 2019-07-15 |  |  |  |  |  |  |  |  |  |  |
| A43442 |  | Valve and Accessories Installation | 20d | 2019-06-18 | 2019-07-06 | A43432, A43462 | 125.25d | 0d | Fire Fighting Crew [200 h] | 18.86 | 1627 | MEP | CON | 4 | MB |
| A43452 |  | Leak Test | 10d | 2019-07-07 | 2019-07-15 | A43442 | 125.25d | 29d | Fire Fighting Crew [100 h] | 9.43 | 1631 | MEP | CON | 4 | MB |
|  | 1.4.1.4.1.1.4.1.4.-2 | **FF_Final Fix** |  | 2019-08-22 | 2019-09-15 |  |  |  |  |  |  |  |  |  |  |
| A43472 |  | Installation of Sprinklers | 15d | 2019-08-22 | 2019-09-05 | A43432, A43442, A43452, 1F5-FNS-B04-180, 1F5-FNS-B04-410 | 113.25d | 0d | Fire Fighting Crew [150 h] | 14.15 | 1633 | MEP | CON | 4 | MB |
| A43482 |  | Instalaltion of Fire Extinguisher | 10d | 2019-09-05 | 2019-09-15 | A43432, A43472, A43812 FF, LOE-SUM3-230 FF | 168.25d | 168.75d | Fire Fighting Crew [100 h] | 9.43 |  | MEP | CON | 4 | MB |
| A43812 |  | Installation of Fire hose Cabinet | 5d | 2019-09-05 | 2019-09-10 | A43432, A43472 | 173.25d | 5d | Fire Fighting Crew [50 h] | 4.71 |  | MEP |  | 4 | MB |
|  | 2 | **B04 - TECHINICAL ZONE 05** |  | 2019-04-17 | 2019-08-29 |  |  |  |  |  |  |  |  |  |  |
|  | 1.4.1.4.1.1.4.1.1 | **HVAC SYSTEM** |  | 2019-04-17 | 2019-08-20 |  |  |  |  |  |  |  |  |  |  |
|  | 1.4.1.4.1.1.4.1.1.1. | **1st Fix** |  | 2019-04-17 | 2019-05-04 |  |  |  |  |  |  |  |  |  |  |
| A45582 |  | Hanger and support Installation - Duct | 6d | 2019-04-17 | 2019-04-22 | RM110 | 172.25d | 0d | Mechanical Crew [60 h] | 5.66 | 1546 | MEP | CON | 5 | MB |
| A45652 |  | Hanger and support Installation - CHW | 6d | 2019-04-17 | 2019-04-22 | A45582 SS | 172.25d | 0d | Mechanical Crew [60 h] | 5.66 |  | MEP |  | 5 | MB |
| A45562 |  | Duct Installation | 12d | 2019-04-18 | 2019-04-30 | A45582 SS+2d | 205.25d | 0d | Duct Installation [260 Sqmt]; HVAC [780 h] | 73.55 | 1549 | MEP | CON | 5 | MB |
| A45572 |  | Duct Insulation | 8d | 2019-04-22 | 2019-04-29 | A45562 SS+3d | 229.25d | 98.5d | Duct Insulation [263 Sqmt]; HVAC [190 h] | 17.92 | 1552 | MEP | CON | 5 | MB |
| A45672 |  | Chilled Water Piping Installation | 12d | 2019-04-22 | 2019-05-04 | A45652 | 172.25d | 0d | Mechanical Crew [120 h] | 11.32 |  | MEP |  | 5 | MB |
|  | 1.4.1.4.1.1.4.1.1.-1 | **2nd Fix** |  | 2019-04-30 | 2019-05-22 |  |  |  |  |  |  |  |  |  |  |
| A45662 |  | Installation of Duct Accessories (VD, FD, MSD etc....) | 12d | 2019-04-30 | 2019-05-11 | A45562 | 216.25d | 85.5d | Mechanical Crew [120 h] | 11.32 |  | MEP |  | 5 | MB |
| A45762 |  | CRAC Units Installation | 15d | 2019-04-30 | 2019-05-14 | A45562 | 205.25d | 9d | Mechanical Crew [150 h] | 14.15 |  | MEP |  | 5 | MB |
| A45772 |  | FCU Installation | 15d | 2019-04-30 | 2019-05-14 | A45562 | 205.25d | 9d | Mechanical Crew [150 h] | 14.15 |  | MEP |  | 5 | MB |
| A45782 |  | VRF DX Units Installation | 12d | 2019-04-30 | 2019-05-11 | A45562 | 208.25d | 12d | Mechanical Crew [120 h] | 11.32 |  | MEP |  | 5 | MB |
| A45792 |  | Installation of Attenuators | 10d | 2019-04-30 | 2019-05-09 | A45562 | 210.25d | 14d | Mechanical Crew [100 h] | 9.43 |  | MEP |  | 5 | MB |
| A45802 |  | Installation of HVAC Fans | 10d | 2019-04-30 | 2019-05-09 | A45562 | 210.25d | 14d | Mechanical Crew [100 h] | 9.43 |  | MEP |  | 5 | MB |
| A45822 |  | Pressurization Unit | 8d | 2019-04-30 | 2019-05-07 | A45562 | 212.25d | 16d | Mechanical Crew [80 h] | 7.54 |  | MEP |  | 5 | MB |
| A45832 |  | Dosing pot | 5d | 2019-04-30 | 2019-05-05 | A45562 | 215.25d | 19d | Mechanical Crew [50 h] | 4.71 |  | MEP |  | 5 | MB |
| A45852 |  | Air Handling Units Installation | 12d | 2019-04-30 | 2019-05-11 | A45562 | 208.25d | 12d | Mechanical Crew [120 h] | 11.32 |  | MEP |  | 5 | MB |
| A45692 |  | Valves and Accessories | 10d | 2019-05-04 | 2019-05-13 | A45672 | 172.25d | 0d | Mechanical Crew [100 h] | 9.43 |  | MEP |  | 5 | MB |
| A45812 |  | Air-Cooled Chillers | 15d | 2019-05-04 | 2019-05-18 | A45672 | 201.25d | 5d | Mechanical Crew [150 h] | 14.15 |  | MEP |  | 5 | MB |
| A45862 |  | Chilled Water Pump Installation | 12d | 2019-05-04 | 2019-05-14 | A45672 | 204.25d | 8d | Mechanical Crew [120 h] | 11.32 |  | MEP |  | 5 | MB |
| A45702 |  | Chilled Water Pipe Insulation and Cladding | 10d | 2019-05-13 | 2019-05-22 | A45672, A45692 | 172.25d | 0d | Mechanical Crew [100 h] | 9.43 |  | MEP |  | 5 | MB |

| ID | WBS | Activity | Duration | Start | Finish | Predecessors | Total float | Free float | Resources | Cost | Discipline | AREA | LOCATION | MSP Activity ID | MEP-Phase |
| --- | --- | --- | --- | --- | --- | --- | --- | --- | --- | --- | --- | --- | --- | --- | --- |
|  | 1.4.1.4.1.1.4.1.1.-2 | **HVAC_Final Fix** |  | 2019-05-22 | 2019-08-20 |  |  |  |  |  |  |  |  |  |  |
| A45842 |  | Equuipment Connection | 8d | 2019-05-22 | 2019-05-29 | A45862, A45852, A45812, A45802, A45792, A45762, A45772, A45782, A45832, A45822, A45702 | 196.25d | 65.5d | Mechanical Crew [80 h] | 7.54 | MEP | 5 | MB |  |  |
| A45682 |  | Air Outlets (Grills, Diffusers, Registers etc...) | 15d | 2019-08-03 | 2019-08-20 | A45662, A45562, A45572, A45842, 1F5-FNS-B04-180 | 130.75d | 121.25d | Mechanical Crew [150 h] | 14.15 | MEP | 5 | MB |  |  |
|  | 1.4.1.4.1.1.4.1.2 | **PLUMBING SYSTEM** |  | 2019-04-17 | 2019-08-14 |  |  |  |  |  |  |  |  |  |  |
|  | 1.4.1.4.1.1.4.1.2.1. | **1st Fix** |  | 2019-04-17 | 2019-05-11 |  |  |  |  |  |  |  |  |  |  |
| A45442 |  | Hanger and support Installation | 10d | 2019-04-17 | 2019-04-25 | RM110 | 168.25d | 0d | Plumbing Crew [100 h] | 9.43 | MEP | 5 | MB | 1566 | CON |
| A45482 |  | Drainage and Vent Pipe & Fittings | 20d | 2019-04-22 | 2019-05-09 | A45442 SS+5d | 225.25d | 1d | Plumbing Crew [200 h] | 18.86 | MEP | 5 | MB | 1573 | CON |
| A45452 |  | Domestic Water Pipe & Fittings | 20d | 2019-04-22 | 2019-05-11 | A45442 SS+6d | 168.25d | 0d | Plumbing Crew [200 h] | 18.86 | MEP | 5 | MB | 1570 | CON |
|  | 1.4.1.4.1.1.4.1.2.-1 | **2nd Fix** |  | 2019-05-11 | 2019-05-26 |  |  |  |  |  |  |  |  |  |  |
| A45462 |  | Domestic Water Valves | 12d | 2019-05-11 | 2019-05-22 | A45452 | 168.25d | 0d | Plumbing Crew [120 h] | 11.32 | MEP | 5 | MB | 1571 | CON |
| A45722 |  | Sewege Pumps Installation | 5d | 2019-05-11 | 2019-05-15 | A45482, A45452 | 224.25d | 88d | Plumbing Crew [50 h] | 4.71 | MEP | 5 | MB |  |  |
| A45472 |  | Leak Test | 4d | 2019-05-22 | 2019-05-26 | A45462 | 168.25d | 62d | Plumbing Crew [40 h] | 3.77 | MEP | 5 | MB | 1572 | CON |
|  | 1.4.1.4.1.1.4.1.2.-2 | **PLM_Final Fix** |  | 2019-08-13 | 2019-08-14 |  |  |  |  |  |  |  |  |  |  |
| A45712 |  | Water Heaters | 2d | 2019-08-13 | 2019-08-14 | A45472, A45482, A45452, 1F5-FNS-B04-190 | 136.25d | 0d | Plumbing Crew [20 h] | 1.89 | MEP | 5 | MB |  |  |
| A45732 |  | Floor Drain | 2d | 2019-08-13 | 2019-08-14 | A45712 SS | 136.25d | 0d | Plumbing Crew [20 h] | 1.89 | MEP | 5 | MB |  |  |
| A45742 |  | Wash Basin / Water Closet | 2d | 2019-08-13 | 2019-08-14 | A45732 SS | 136.25d | 0d | Plumbing Crew [20 h] | 1.89 | MEP | 5 | MB |  |  |
| A45752 |  | Eye Wash | 2d | 2019-08-13 | 2019-08-14 | A45742 SS, A45722 | 136.25d | 113.75d | Plumbing Crew [20 h] | 1.89 | MEP | 5 | MB |  |  |
|  | 1.4.1.4.1.1.4.1.3 | **ELECTRICAL / CONTROLS** |  | 2019-04-17 | 2019-08-15 |  |  |  |  |  |  |  |  |  |  |
|  | 1.4.1.4.1.1.4.1.3.1. | **1st Fix** |  | 2019-04-17 | 2019-05-16 |  |  |  |  |  |  |  |  |  |  |
| A45542 |  | Installation of Conduits and Boxes | 12d | 2019-04-17 | 2019-04-28 | RM110 | 106.25d | 0d | Electrical Crew [120 h] | 11.32 | MEP | 5 | MB | 1592 | CON |
| A45552 |  | Installation of Cable Tray, Ladder and Trunk | 20d | 2019-04-28 | 2019-05-16 | A45542 | 189.25d | 0d | Electrical Crew [200 h] | 18.86 | MEP | 5 | MB | 1593 | CON |
|  | 1.4.1.4.1.1.4.1.3.-1 | **2nd Fix** |  | 2019-04-28 | 2019-07-27 |  |  |  |  |  |  |  |  |  |  |
| A45512 |  | Grounding and Bonding Installation | 20d | 2019-04-28 | 2019-05-16 | A45542 | 106.25d | 0d | Electrical Crew [200 h] | 18.86 | MEP | 5 | MB | 1596 | CON |
| A45872 |  | Wire Pulling | 20d | 2019-05-16 | 2019-06-08 | A45512 | 106.25d | 0d | Electrical Crew [200 h] | 18.86 | MEP | 5 | MB |  |  |
| A45932 |  | Installation of Bus Duct System | 20d | 2019-05-16 | 2019-06-08 | A45552 | 189.25d | 52d | Electrical Crew [200 h] | 18.86 | MEP | 5 | MB |  |  |
| A45492 |  | Power Cable Laying | 25d | 2019-06-08 | 2019-07-01 | A45872, A45512 | 106.25d | 0d | Electrical Crew [250 h] | 23.58 | MEP | 5 | MB | 1600 | CON |
| A45502 |  | Continuity Test - Power Cables | 4d | 2019-07-01 | 2019-07-04 | A45492 | 160.25d | 23d | Electrical Crew [40 h] | 3.77 | MEP | 5 | MB | 1601 | CON |
| A45882 |  | Installation of Central Battery Equipment | 6d | 2019-07-01 | 2019-07-07 | A45492, A45872 | 158.25d | 21d | Electrical Crew [60 h] | 5.66 | MEP | 5 | MB |  |  |
| A45892 |  | Installation of Disconnect Switch | 8d | 2019-07-01 | 2019-07-08 | A45492, A45872 | 156.25d | 19d | Electrical Crew [80 h] | 7.54 | MEP | 5 | MB |  |  |
| A45912 |  | Installation of Switch Boards (MDB, EMDB) | 15d | 2019-07-01 | 2019-07-15 | A45492, A45872 | 106.25d | 0d | Electrical Crew [150 h] | 14.15 | MEP | 5 | MB |  |  |
| A45922 |  | Installation of Panel Boards | 15d | 2019-07-01 | 2019-07-15 | A45492, A45872 | 106.25d | 0d | Electrical Crew [150 h] | 14.15 | MEP | 5 | MB |  |  |
| A45942 |  | Installation of MCC | 15d | 2019-07-01 | 2019-07-15 | A45492, A45872 | 106.25d | 0d | Electrical Crew [150 h] | 14.15 | MEP | 5 | MB |  |  |
| A45952 |  | Installation of Lighting Control System | 12d | 2019-07-01 | 2019-07-13 | A45492, A45872 | 109.25d | 3d | Electrical Crew [120 h] | 11.32 | MEP | 5 | MB |  |  |
| A45902 |  | Installation of Wiring Devices and Outlets | 12d | 2019-07-15 | 2019-07-27 | A45872, A45942, A45922, A45912, A45952 | 106.25d | 0d | Electrical Crew [120 h] | 11.32 | MEP | 5 | MB |  |  |

| ID | WBS | Activity | Type | Duration | Start | Finish | Predecessors | Total float | Free float | Calendar | Resources | Cost | Discipline | AREA | LOCATION | MSP Activity ID | MEP-Phase |
| --- | --- | --- | --- | --- | --- | --- | --- | --- | --- | --- | --- | --- | --- | --- | --- | --- | --- |
|  | 1.4.1.4.1.1.4.1.3.-2 | **Elec._Final Fix** |  |  | 2019-07-15 | 2019-08-15 |  |  |  |  |  |  |  |  |  |  |  |
| A45962 |  | Panel Board Termination |  | 8d | 2019-07-15 | 2019-07-22 | A45912, A45922, A45942 | 147.25d | 11.5d |  | Electrical Crew [80 h] | 7.54 | MEP | 5 | MB |  |  |
| A45532 |  | Wiring devices Termination |  | 6d | 2019-07-27 | 2019-07-31 | A45882, A45892, A45932, A45952, A45902, A45502 | 137.25d | 1.5d |  | Electrical Crew [60 h] | 5.66 | MEP | 5 | MB | 1617 | CON |
| A45522 |  | Lighting Fixtures Installation and Termination |  | 10d | 2019-08-03 | 2019-08-15 | A45492, A45872, A45962, A45532, 1F5-FNS-B04-180 | 135.75d | 121.25d |  | Electrical Crew [100 h] | 9.43 | MEP | 5 | MB | 1616 | CON |
|  | 1.4.1.4.1.1.4.1.4 | **FIRE FIGHTING SYSTEM** |  |  | 2019-04-17 | 2019-08-29 |  |  |  |  |  |  |  |  |  |  |  |
|  | 1.4.1.4.1.1.4.1.4.1. | **1st Fix** |  |  | 2019-04-17 | 2019-05-28 |  |  |  |  |  |  |  |  |  |  |  |
| A45622 |  | Fire Fighting Hangers & Supports |  | 15d | 2019-04-17 | 2019-04-30 | RM110 | 135.25d | 0d |  | Fire Fighting Crew [150 h] | 14.15 | MEP | 5 | MB | 1622 | CON |
| A45592 |  | Pipe Installation |  | 30d | 2019-05-01 | 2019-05-28 | A45622 | 135.25d | 0d |  | FF pipe [206 Limt]; FIRE FIGHTING [361 h] | 34.04 | MEP | 5 | MB | 1625 | CON |
|  | 1.4.1.4.1.1.4.1.4.-1 | **2nd Fix** |  |  | 2019-05-29 | 2019-06-29 |  |  |  |  |  |  |  |  |  |  |  |
| A45602 |  | Valve and Accessories Installation |  | 20d | 2019-05-29 | 2019-06-19 | A45592, A45622 | 135.25d | 0d |  | Fire Fighting Crew [200 h] | 18.86 | MEP | 5 | MB | 1627 | CON |
| A45612 |  | Leak Test |  | 10d | 2019-06-20 | 2019-06-29 | A45602 | 135.25d | 29d |  | Fire Fighting Crew [100 h] | 9.43 | MEP | 5 | MB | 1631 | CON |
|  | 1.4.1.4.1.1.4.1.4.-2 | **FF_Final Fix** |  |  | 2019-08-03 | 2019-08-29 |  |  |  |  |  |  |  |  |  |  |  |
| A45632 |  | Installation of Sprinklers |  | 15d | 2019-08-03 | 2019-08-20 | A45592, A45602, A45612, 1F5-FNS-B04-180 | 130.75d | 0d |  | Fire Fighting Crew [150 h] | 14.15 | MEP | 5 | MB | 1633 | CON |
| A45642 |  | Instalaltion of Fire Extinguisher |  | 10d | 2019-08-20 | 2019-08-29 | A45592, A45632, A45972 FF | 185.75d | 186.25d |  | Fire Fighting Crew [100 h] | 9.43 | MEP | 5 | MB |  | CON |
| A45972 |  | Installation of Fire hose Cabinet |  | 5d | 2019-08-20 | 2019-08-25 | A45592, A45632 | 190.75d | 5d |  | Fire Fighting Crew [50 h] | 4.71 | MEP | 5 | MB |  |  |
|  | 6 | **CENTRAL TECHINICAL - ZONE 03** |  |  | 2019-05-23 | 2019-10-06 |  |  |  |  |  |  |  |  |  |  |  |
| LOE-SUM3-240 |  | Central . B04 - MEP Works; 1st & 2nd Fix | level of effort | 111.5d | 2019-05-23 | 2019-09-04 | RM120 | 93d | 0d | Saudi |  |  | MEP |  |  |  |  |
| LOE-SUM3-250 |  | Central . B04 - MEP Works; Final fix | level of effort | 103.75d | 2019-07-01 | 2019-10-06 | LOE-SUM3-240, A48002 SS | 147d | 0d | Saudi |  |  | MEP |  |  |  |  |
|  | 3 | **B04 - TECHINICAL ZONE 03** |  |  | 2019-05-23 | 2019-10-06 |  |  |  |  |  |  |  |  |  |  |  |
|  | 1.4.1.4.1.1.4.1.1 | **HVAC SYSTEM** |  |  | 2019-05-23 | 2019-09-26 |  |  |  |  |  |  |  |  |  |  |  |
|  | 1.4.1.4.1.1.4.1.1.1. | **1st Fix** |  |  | 2019-05-23 | 2019-06-12 |  |  |  |  |  |  |  |  |  |  |  |
| A47742 |  | Hanger and support Installation - Duct |  | 6d | 2019-05-23 | 2019-05-28 | RM120 | 148.5d | 0d |  | Mechanical Crew [60 h] | 5.66 | MEP | 3 | MB | 1546 | CON |
| A47812 |  | Hanger and support Installation - CHW |  | 6d | 2019-05-23 | 2019-05-28 | A47742 SS | 148.5d | 0d |  | Mechanical Crew [60 h] | 5.66 | MEP | 3 | MB |  |  |
| A47722 |  | Duct Installation |  | 12d | 2019-05-25 | 2019-06-09 | A47742 SS+2d | 166.5d | 0d |  | Duct Installation [520 Sqmt]; HVAC [1560 h] | 147.11 | MEP | 3 | MB | 1549 | CON |
| A47732 |  | Duct Insulation |  | 8d | 2019-05-28 | 2019-06-08 | A47722 SS+3d | 190.5d | 98.5d |  | Duct Insulation [535 Sqmt]; HVAC [380 h] | 35.83 | MEP | 3 | MB | 1552 | CON |
| A47832 |  | Chilled Water Piping Installation |  | 12d | 2019-05-28 | 2019-06-12 | A47812 | 148.5d | 0d |  | Mechanical Crew [120 h] | 11.32 | MEP | 3 | MB |  |  |

| ID | WBS | Activity | Duration | Start | Finish | Predecessors | Total float | Free float | Resources | Cost | Discipline | AREA | LOCATION | MSP Activity ID | MEP-Phase |
| --- | --- | --- | --- | --- | --- | --- | --- | --- | --- | --- | --- | --- | --- | --- | --- |
|  | 1.4.1.4.1.1.4.1.1.-1 | **2nd Fix** |  | 2019-06-09 | 2019-07-01 |  |  |  |  |  |  |  |  |  |  |
| A47822 |  | Installation of Duct Accessories (VD, FD, MSD etc....) | 12d | 2019-06-09 | 2019-06-19 | A47722 | 177.5d | 85.5d | Mechanical Crew [120 h] | 11.32 | MEP | 3 | MB |  |  |
| A47922 |  | CRAC Units Installation | 15d | 2019-06-09 | 2019-06-23 | A47722 | 166.5d | 9d | Mechanical Crew [150 h] | 14.15 | MEP | 3 | MB |  |  |
| A47932 |  | FCU Installation | 15d | 2019-06-09 | 2019-06-23 | A47722 | 166.5d | 9d | Mechanical Crew [150 h] | 14.15 | MEP | 3 | MB |  |  |
| A47942 |  | VRF DX Units Installation | 12d | 2019-06-09 | 2019-06-19 | A47722 | 169.5d | 12d | Mechanical Crew [120 h] | 11.32 | MEP | 3 | MB |  |  |
| A47952 |  | Installation of Attenuators | 10d | 2019-06-09 | 2019-06-18 | A47722 | 171.5d | 14d | Mechanical Crew [100 h] | 9.43 | MEP | 3 | MB |  |  |
| A47962 |  | Installation of HVAC Fans | 10d | 2019-06-09 | 2019-06-18 | A47722 | 171.5d | 14d | Mechanical Crew [100 h] | 9.43 | MEP | 3 | MB |  |  |
| A47982 |  | Pressurization Unit | 8d | 2019-06-09 | 2019-06-16 | A47722 | 173.5d | 16d | Mechanical Crew [80 h] | 7.54 | MEP | 3 | MB |  |  |
| A47992 |  | Dosing pot | 5d | 2019-06-09 | 2019-06-13 | A47722 | 176.5d | 19d | Mechanical Crew [50 h] | 4.71 | MEP | 3 | MB |  |  |
| A48012 |  | Air Handling Units Installation | 12d | 2019-06-09 | 2019-06-19 | A47722 | 169.5d | 12d | Mechanical Crew [120 h] | 11.32 | MEP | 3 | MB |  |  |
| A47852 |  | Valves and Accessories | 10d | 2019-06-12 | 2019-06-22 | A47832 | 148.5d | 0d | Mechanical Crew [100 h] | 9.43 | MEP | 3 | MB |  |  |
| A47972 |  | Air-Cooled Chillers | 15d | 2019-06-12 | 2019-06-26 | A47832 | 162.5d | 5d | Mechanical Crew [150 h] | 14.15 | MEP | 3 | MB |  |  |
| A48022 |  | Chilled Water Pump Installation | 12d | 2019-06-12 | 2019-06-23 | A47832 | 165.5d | 8d | Mechanical Crew [120 h] | 11.32 | MEP | 3 | MB |  |  |
| A47862 |  | Chilled Water Pipe Insulation and Cladding | 10d | 2019-06-22 | 2019-07-01 | A47832, A47852 | 148.5d | 0d | Mechanical Crew [100 h] | 9.43 | MEP | 3 | MB |  |  |
|  | 1.4.1.4.1.1.4.1.1.-2 | **HVAC_Final Fix** |  | 2019-07-01 | 2019-09-26 |  |  |  |  |  |  |  |  |  |  |
| A48002 |  | Equuipment Connection | 8d | 2019-07-01 | 2019-07-08 | A48022, A48012, A47972, A47962, A47952, A47922, A47932, A47942, A47992, A47982, A47862 | 157.5d | 65.5d | Mechanical Crew [80 h] | 7.54 | MEP | 3 | MB |  |  |
| A47842 |  | Air Outlets (Grills, Diffusers, Registers etc...) | 15d | 2019-09-11 | 2019-09-26 | A47822, A47722, A47732, A48002, 1F5-FNS-B04-620 | 92d | 82.5d | Mechanical Crew [150 h] | 14.15 | MEP | 3 | MB |  |  |
|  | 1.4.1.4.1.1.4.1.2 | **PLUMBING SYSTEM** |  | 2019-05-23 | 2019-09-19 |  |  |  |  |  |  |  |  |  |  |
|  | 1.4.1.4.1.1.4.1.2.1. | **1st Fix** |  | 2019-05-23 | 2019-06-19 |  |  |  |  |  |  |  |  |  |  |
| A47602 |  | Hanger and support Installation | 10d | 2019-05-23 | 2019-06-01 | RM120 | 144.5d | 0d | Plumbing Crew [100 h] | 9.43 | MEP | 3 | MB | 1566 | CON |
| A47642 |  | Drainage and Vent Pipe & Fittings | 20d | 2019-05-28 | 2019-06-18 | A47602 SS+5d | 186.5d | 1d | Plumbing Crew [200 h] | 18.86 | MEP | 3 | MB | 1573 | CON |
| A47612 |  | Domestic Water Pipe & Fittings | 20d | 2019-05-28 | 2019-06-19 | A47602 SS+6d | 144.5d | 0d | Plumbing Crew [200 h] | 18.86 | MEP | 3 | MB | 1570 | CON |
|  | 1.4.1.4.1.1.4.1.2.-1 | **2nd Fix** |  | 2019-06-19 | 2019-07-04 |  |  |  |  |  |  |  |  |  |  |
| A47622 |  | Domestic Water Valves | 12d | 2019-06-19 | 2019-07-01 | A47612 | 144.5d | 0d | Plumbing Crew [120 h] | 11.32 | MEP | 3 | MB | 1571 | CON |
| A47882 |  | Sewege Pumps Installation | 5d | 2019-06-19 | 2019-06-24 | A47642, A47612 | 185.5d | 88d | Plumbing Crew [50 h] | 4.71 | MEP | 3 | MB |  |  |
| A47632 |  | Leak Test | 4d | 2019-07-01 | 2019-07-04 | A47622 | 144.5d | 62d | Plumbing Crew [40 h] | 3.77 | MEP | 3 | MB | 1572 | CON |

| ID | WBS | Activity | Duration | Start | Finish | Predecessors | Total float | Free float | Resources | Cost | Discipline | AREA | LOCATION | MSP Activity ID | MEP-Phase |
| --- | --- | --- | --- | --- | --- | --- | --- | --- | --- | --- | --- | --- | --- | --- | --- |
|  | 1.4.1.4.1.1.4.1.2.-2 | **PLM_Final Fix** |  | 2019-09-18 | 2019-09-19 |  |  |  |  |  |  |  |  |  |  |
| A47872 |  | Water Heaters | 2d | 2019-09-18 | 2019-09-19 | A47632, A47642, A47612, 1F5-FNS-B04-630 | 97.5d | 0d | Plumbing Crew [20 h] | 1.89 | MEP | 3 | MB |  |  |
| A47892 |  | Floor Drain | 2d | 2019-09-18 | 2019-09-19 | A47872 SS | 97.5d | 0d | Plumbing Crew [20 h] | 1.89 | MEP | 3 | MB |  |  |
| A47902 |  | Wash Basin / Water Closet | 2d | 2019-09-18 | 2019-09-19 | A47892 SS | 97.5d | 0d | Plumbing Crew [20 h] | 1.89 | MEP | 3 | MB |  |  |
| A47912 |  | Eye Wash | 2d | 2019-09-18 | 2019-09-19 | A47902 SS, A47882 | 97.5d | 75d | Plumbing Crew [20 h] | 1.89 | MEP | 3 | MB |  |  |
|  | 1.4.1.4.1.1.4.1.3 | **ELECTRICAL / CONTROLS** |  | 2019-05-23 | 2019-09-21 |  |  |  |  |  |  |  |  |  |  |
|  | 1.4.1.4.1.1.4.1.3.1. | **1st Fix** |  | 2019-05-23 | 2019-06-25 |  |  |  |  |  |  |  |  |  |  |
| A47702 |  | Installation of Conduits and Boxes | 12d | 2019-05-23 | 2019-06-03 | RM120 | 82.5d | 0d | Electrical Crew [120 h] | 11.32 | MEP | 3 | MB | 1592 | CON |
| A47712 |  | Installation of Cable Tray, Ladder and Trunk | 20d | 2019-06-03 | 2019-06-25 | A47702 | 150.5d | 0d | Electrical Crew [200 h] | 18.86 | MEP | 3 | MB | 1593 | CON |
|  | 1.4.1.4.1.1.4.1.3.-1 | **2nd Fix** |  | 2019-06-03 | 2019-09-04 |  |  |  |  |  |  |  |  |  |  |
| A47672 |  | Grounding and Bonding Installation | 20d | 2019-06-03 | 2019-06-25 | A47702 | 82.5d | 0d | Electrical Crew [200 h] | 18.86 | MEP | 3 | MB | 1596 | CON |
| A48032 |  | Wire Pulling | 20d | 2019-06-25 | 2019-07-14 | A47672 | 82.5d | 0d | Electrical Crew [200 h] | 18.86 | MEP | 3 | MB |  |  |
| A48092 |  | Installation of Bus Duct System | 20d | 2019-06-25 | 2019-07-14 | A47712 | 150.5d | 52d | Electrical Crew [200 h] | 18.86 | MEP | 3 | MB |  |  |
| A47652 |  | Power Cable Laying | 25d | 2019-07-14 | 2019-08-06 | A48032, A47672 | 82.5d | 0d | Electrical Crew [250 h] | 23.58 | MEP | 3 | MB | 1600 | CON |
| A47662 |  | Continuity Test - Power Cables | 4d | 2019-08-06 | 2019-08-13 | A47652 | 121.5d | 23d | Electrical Crew [40 h] | 3.77 | MEP | 3 | MB | 1601 | CON |
| A48042 |  | Installation of Central Battery Equipment | 6d | 2019-08-06 | 2019-08-15 | A47652, A48032 | 119.5d | 21d | Electrical Crew [60 h] | 5.66 | MEP | 3 | MB |  |  |
| A48052 |  | Installation of Disconnect Switch | 8d | 2019-08-06 | 2019-08-17 | A47652, A48032 | 117.5d | 19d | Electrical Crew [80 h] | 7.54 | MEP | 3 | MB |  |  |
| A48072 |  | Installation of Switch Boards (MDB, EMDB) | 15d | 2019-08-06 | 2019-08-24 | A47652, A48032 | 82.5d | 0d | Electrical Crew [150 h] | 14.15 | MEP | 3 | MB |  |  |
| A48082 |  | Installation of Panel Boards | 15d | 2019-08-06 | 2019-08-24 | A47652, A48032 | 82.5d | 0d | Electrical Crew [150 h] | 14.15 | MEP | 3 | MB |  |  |
| A48102 |  | Installation of MCC | 15d | 2019-08-06 | 2019-08-24 | A47652, A48032 | 82.5d | 0d | Electrical Crew [150 h] | 14.15 | MEP | 3 | MB |  |  |
| A48112 |  | Installation of Lighting Control System | 12d | 2019-08-06 | 2019-08-21 | A47652, A48032 | 85.5d | 3d | Electrical Crew [120 h] | 11.32 | MEP | 3 | MB |  |  |
| A48062 |  | Installation of Wiring Devices and Outlets | 12d | 2019-08-24 | 2019-09-04 | A48032, A48102, A48082, A48072, A48112 | 82.5d | 0d | Electrical Crew [120 h] | 11.32 | MEP | 3 | MB |  |  |
|  | 1.4.1.4.1.1.4.1.3.-2 | **Elec._Final Fix** |  | 2019-08-24 | 2019-09-21 |  |  |  |  |  |  |  |  |  |  |
| A48122 |  | Panel Board Termination | 8d | 2019-08-24 | 2019-08-31 | A48072, A48082, A48102 | 108.5d | 11.5d | Electrical Crew [80 h] | 7.54 | MEP | 3 | MB |  |  |
| A47692 |  | Wiring devices Termination | 6d | 2019-09-04 | 2019-09-09 | A48042, A48052, A48092, A48112, A48062, A47662 | 98.5d | 1.5d | Electrical Crew [60 h] | 5.66 | MEP | 3 | MB | 1617 | CON |
| A47682 |  | Lighting Fixtures Installation and Termination | 10d | 2019-09-11 | 2019-09-21 | A47652, A48032, A48122, A47692, 1F5-FNS-B04-620 | 97d | 82.5d | Electrical Crew [100 h] | 9.43 | MEP | 3 | MB | 1616 | CON |

| ID | WBS | Activity | Type | Duration | Start | Finish | Predecessors | Total float | Free float | Calendar | Resources | Cost | MSP Activity ID | Discipline | MEP-Phase | AREA | LOCATION |
| --- | --- | --- | --- | --- | --- | --- | --- | --- | --- | --- | --- | --- | --- | --- | --- | --- | --- |
|  | 1.4.1.4.1.1.4.1.4 | **FIRE FIGHTING SYSTEM** |  |  | 2019-05-23 | 2019-10-06 |  |  |  |  |  |  |  |  |  |  |  |
|  | 1.4.1.4.1.1.4.1.4.1. | **1st Fix** |  |  | 2019-05-23 | 2019-07-07 |  |  |  |  |  |  |  |  |  |  |  |
| A47782 |  | Fire Fighting Hangers & Supports |  | 15d | 2019-05-23 | 2019-06-09 | RM120 | 111.5d | 0d |  | Fire Fighting Crew [150 h] | 14.15 | 1622 | MEP | CON | 3 | MB |
| A47752 |  | Pipe Installation |  | 30d | 2019-06-10 | 2019-07-07 | A47782 | 111.5d | 0d |  | FIRE FIGHTING [721 h]; FF pipe [412 Limt] | 67.99 | 1625 | MEP | CON | 3 | MB |
|  | 1.4.1.4.1.1.4.1.4.-1 | **2nd Fix** |  |  | 2019-07-08 | 2019-08-04 |  |  |  |  |  |  |  |  |  |  |  |
| A47762 |  | Valve and Accessories Installation |  | 20d | 2019-07-08 | 2019-07-25 | A47752, A47782 | 111.5d | 0d |  | Fire Fighting Crew [200 h] | 18.86 | 1627 | MEP | CON | 3 | MB |
| A47772 |  | Leak Test |  | 10d | 2019-07-27 | 2019-08-04 | A47762 | 111.5d | 29d |  | Fire Fighting Crew [100 h] | 9.43 | 1631 | MEP | CON | 3 | MB |
|  | 1.4.1.4.1.1.4.1.4.-2 | **FF_Final Fix** |  |  | 2019-09-11 | 2019-10-06 |  |  |  |  |  |  |  |  |  |  |  |
| A47792 |  | Installation of Sprinklers |  | 15d | 2019-09-11 | 2019-09-26 | A47752, A47762, A47772, 1F5-FNS-B04-620 | 92d | 0d |  | Fire Fighting Crew [150 h] | 14.15 | 1633 | MEP | CON | 3 | MB |
| A47802 |  | Instalaltion of Fire Extinguisher |  | 10d | 2019-09-26 | 2019-10-06 | A47752, A47792, A48132 FF, LOE-SUM3-250 FF | 147d | 147.5d |  | Fire Fighting Crew [100 h] | 9.43 |  | MEP | CON | 3 | MB |
| A48132 |  | Installation of Fire hose Cabinet |  | 5d | 2019-09-26 | 2019-10-01 | A47752, A47792 | 152d | 5d |  | Fire Fighting Crew [50 h] | 4.71 |  | MEP |  | 3 | MB |
|  | 1 | **NORTH TECHINICAL - ZONE 01 AND 02** |  |  | 2019-06-16 | 2019-11-14 |  |  |  |  |  |  |  |  |  |  |  |
| LOE-SUM3-260 |  | North . B04 - MEP Works; 1st & 2nd Fix | level of effort | 130.5d | 2019-06-16 | 2019-10-15 | RM130 | 49.5d | 0d | Saudi |  |  |  | MEP |  |  |  |
| LOE-SUM3-270 |  | North . B04 - MEP Works; Final fix | level of effort | 125d | 2019-07-21 | 2019-11-14 | LOE-SUM3-260, A50162 SS | 104.5d | 0d | Saudi |  |  |  | MEP |  |  |  |
|  | 4 | **B04 - TECHINICAL ZONE 01** |  |  | 2019-07-06 | 2019-11-14 |  |  |  |  |  |  |  |  |  |  |  |
|  | 1.4.1.4.1.1.4.1.1 | **HVAC SYSTEM** |  |  | 2019-07-06 | 2019-11-05 |  |  |  |  |  |  |  |  |  |  |  |
|  | 1.4.1.4.1.1.4.1.1.1. | **1st Fix** |  |  | 2019-07-06 | 2019-07-22 |  |  |  |  |  |  |  |  |  |  |  |
| A52062 |  | Hanger and support Installation - Duct |  | 6d | 2019-07-06 | 2019-07-10 | RM140 | 115d | 0d |  | Mechanical Crew [60 h] | 5.66 | 1546 | MEP | CON | 1 | MB |
| A52132 |  | Hanger and support Installation - CHW |  | 6d | 2019-07-06 | 2019-07-10 | A52062 SS | 115d | 0d |  | Mechanical Crew [60 h] | 5.66 |  | MEP |  | 1 | MB |
| A52042 |  | Duct Installation |  | 12d | 2019-07-07 | 2019-07-18 | A52062 SS+2d | 124d | 0d |  | Duct Installation [260 Sqmt]; HVAC [780 h] | 73.55 | 1549 | MEP | CON | 1 | MB |
| A52052 |  | Duct Insulation |  | 8d | 2019-07-10 | 2019-07-17 | A52042 SS+3d | 148d | 98.5d |  | Duct Insulation [263 Sqmt]; HVAC [190 h] | 17.92 | 1552 | MEP | CON | 1 | MB |
| A52152 |  | Chilled Water Piping Installation |  | 12d | 2019-07-10 | 2019-07-22 | A52132 | 115d | 0d |  | Mechanical Crew [120 h] | 11.32 |  | MEP |  | 1 | MB |
|  | 1.4.1.4.1.1.4.1.1.-1 | **2nd Fix** |  |  | 2019-07-18 | 2019-08-13 |  |  |  |  |  |  |  |  |  |  |  |
| A52142 |  | Installation of Duct Accessories (VD, FD, MSD etc....) |  | 12d | 2019-07-18 | 2019-07-29 | A52042 | 135d | 85.5d |  | Mechanical Crew [120 h] | 11.32 |  | MEP |  | 1 | MB |
| A52242 |  | CRAC Units Installation |  | 15d | 2019-07-18 | 2019-08-01 | A52042 | 124d | 9d |  | Mechanical Crew [150 h] | 14.15 |  | MEP |  | 1 | MB |
| A52252 |  | FCU Installation |  | 15d | 2019-07-18 | 2019-08-01 | A52042 | 124d | 9d |  | Mechanical Crew [150 h] | 14.15 |  | MEP |  | 1 | MB |
| A52262 |  | VRF DX Units Installation |  | 12d | 2019-07-18 | 2019-07-29 | A52042 | 127d | 12d |  | Mechanical Crew [120 h] | 11.32 |  | MEP |  | 1 | MB |
| A52272 |  | Installation of Attenuators |  | 10d | 2019-07-18 | 2019-07-28 | A52042 | 129d | 14d |  | Mechanical Crew [100 h] | 9.43 |  | MEP |  | 1 | MB |
| A52282 |  | Installation of HVAC Fans |  | 10d | 2019-07-18 | 2019-07-28 | A52042 | 129d | 14d |  | Mechanical Crew [100 h] | 9.43 |  | MEP |  | 1 | MB |
| A52302 |  | Pressurization Unit |  | 8d | 2019-07-18 | 2019-07-25 | A52042 | 131d | 16d |  | Mechanical Crew [80 h] | 7.54 |  | MEP |  | 1 | MB |
| A52312 |  | Dosing pot |  | 5d | 2019-07-18 | 2019-07-23 | A52042 | 134d | 19d |  | Mechanical Crew [50 h] | 4.71 |  | MEP |  | 1 | MB |
| A52332 |  | Air Handling Units Installation |  | 12d | 2019-07-18 | 2019-07-29 | A52042 | 127d | 12d |  | Mechanical Crew [120 h] | 11.32 |  | MEP |  | 1 | MB |
| A52172 |  | Valves and Accessories |  | 10d | 2019-07-22 | 2019-07-31 | A52152 | 115d | 0d |  | Mechanical Crew [100 h] | 9.43 |  | MEP |  | 1 | MB |
| A52292 |  | Air-Cooled Chillers |  | 15d | 2019-07-22 | 2019-08-05 | A52152 | 120d | 5d |  | Mechanical Crew [150 h] | 14.15 |  | MEP |  | 1 | MB |
| A52342 |  | Chilled Water Pump Installation |  | 12d | 2019-07-22 | 2019-08-01 | A52152 | 123d | 8d |  | Mechanical Crew [120 h] | 11.32 |  | MEP |  | 1 | MB |
| A52182 |  | Chilled Water Pipe Insulation and Cladding |  | 10d | 2019-07-31 | 2019-08-13 | A52152, A52172 | 115d | 0d |  | Mechanical Crew [100 h] | 9.43 |  | MEP |  | 1 | MB |

| ID | WBS | Activity | Duration | Start | Finish | Predecessors | Total float | Free float | Resources | Cost | Discipline | AREA | LOCATION | MSP Activity ID | MEP-Phase |
| --- | --- | --- | --- | --- | --- | --- | --- | --- | --- | --- | --- | --- | --- | --- | --- |
|  | 1.4.1.4.1.1.4.1.1.-2 | **HVAC_Final Fix** |  | 2019-08-13 | 2019-11-05 |  |  |  |  |  |  |  |  |  |  |
| A52322 |  | Equuipment Connection | 8d | 2019-08-13 | 2019-08-20 | A52342, A52332, A52292, A52282, A52272, A52242, A52252, A52262, A52312, A52302, A52182 | 115d | 65.5d | Mechanical Crew [80 h] | 7.54 | MEP | 1 | MB |  |  |
| A52162 |  | Air Outlets (Grills, Diffusers, Registers etc...) | 15d | 2019-10-22 | 2019-11-05 | A52142, A52042, A52052, A52322, 1F5-FNS-B04-1060 | 49.5d | 40d | Mechanical Crew [150 h] | 14.15 | MEP | 1 | MB |  |  |
|  | 1.4.1.4.1.1.4.1.2 | **PLUMBING SYSTEM** |  | 2019-07-06 | 2019-10-30 |  |  |  |  |  |  |  |  |  |  |
|  | 1.4.1.4.1.1.4.1.2.1. | **1st Fix** |  | 2019-07-06 | 2019-07-29 |  |  |  |  |  |  |  |  |  |  |
| A51922 |  | Hanger and support Installation | 10d | 2019-07-06 | 2019-07-14 | RM140 | 111.5d | 0d | Plumbing Crew [100 h] | 9.43 | MEP | 1 | MB | 1566 | CON |
| A51962 |  | Drainage and Vent Pipe & Fittings | 20d | 2019-07-10 | 2019-07-28 | A51922 SS+5d | 144d | 1d | Plumbing Crew [200 h] | 18.86 | MEP | 1 | MB | 1573 | CON |
| A51932 |  | Domestic Water Pipe & Fittings | 20d | 2019-07-10 | 2019-07-29 | A51922 SS+6d | 111.5d | 0d | Plumbing Crew [200 h] | 18.86 | MEP | 1 | MB | 1570 | CON |
|  | 1.4.1.4.1.1.4.1.2.-1 | **2nd Fix** |  | 2019-07-29 | 2019-08-17 |  |  |  |  |  |  |  |  |  |  |
| A51942 |  | Domestic Water Valves | 12d | 2019-07-29 | 2019-08-13 | A51932 | 111.5d | 0d | Plumbing Crew [120 h] | 11.32 | MEP | 1 | MB | 1571 | CON |
| A52202 |  | Sewege Pumps Installation | 5d | 2019-07-29 | 2019-08-03 | A51962, A51932 | 143d | 88d | Plumbing Crew [50 h] | 4.71 | MEP | 1 | MB |  |  |
| A51952 |  | Leak Test | 4d | 2019-08-13 | 2019-08-17 | A51942 | 111.5d | 62d | Plumbing Crew [40 h] | 3.77 | MEP | 1 | MB | 1572 | CON |
|  | 1.4.1.4.1.1.4.1.2.-2 | **PLM_Final Fix** |  | 2019-10-29 | 2019-10-30 |  |  |  |  |  |  |  |  |  |  |
| A52192 |  | Water Heaters | 2d | 2019-10-29 | 2019-10-30 | A51952, A51962, A51932, 1F5-FNS-B04-1070 | 55d | 0d | Plumbing Crew [20 h] | 1.89 | MEP | 1 | MB |  |  |
| A52212 |  | Floor Drain | 2d | 2019-10-29 | 2019-10-30 | A52192 SS | 55d | 0d | Plumbing Crew [20 h] | 1.89 | MEP | 1 | MB |  |  |
| A52222 |  | Wash Basin / Water Closet | 2d | 2019-10-29 | 2019-10-30 | A52212 SS | 55d | 0d | Plumbing Crew [20 h] | 1.89 | MEP | 1 | MB |  |  |
| A52232 |  | Eye Wash | 2d | 2019-10-29 | 2019-10-30 | A52222 SS, A52202 | 55d | 32.5d | Plumbing Crew [20 h] | 1.89 | MEP | 1 | MB |  |  |
|  | 1.4.1.4.1.1.4.1.3 | **ELECTRICAL / CONTROLS** |  | 2019-07-06 | 2019-10-31 |  |  |  |  |  |  |  |  |  |  |
|  | 1.4.1.4.1.1.4.1.3.1. | **1st Fix** |  | 2019-07-06 | 2019-08-04 |  |  |  |  |  |  |  |  |  |  |
| A52022 |  | Installation of Conduits and Boxes | 12d | 2019-07-06 | 2019-07-16 | RM140 | 49.5d | 0d | Electrical Crew [120 h] | 11.32 | MEP | 1 | MB | 1592 | CON |
| A52032 |  | Installation of Cable Tray, Ladder and Trunk | 20d | 2019-07-16 | 2019-08-04 | A52022 | 108d | 0d | Electrical Crew [200 h] | 18.86 | MEP | 1 | MB | 1593 | CON |
|  | 1.4.1.4.1.1.4.1.3.-1 | **2nd Fix** |  | 2019-07-16 | 2019-10-15 |  |  |  |  |  |  |  |  |  |  |
| A51992 |  | Grounding and Bonding Installation | 20d | 2019-07-16 | 2019-08-04 | A52022 | 49.5d | 0d | Electrical Crew [200 h] | 18.86 | MEP | 1 | MB | 1596 | CON |
| A52352 |  | Wire Pulling | 20d | 2019-08-04 | 2019-08-26 | A51992 | 49.5d | 0d | Electrical Crew [200 h] | 18.86 | MEP | 1 | MB |  |  |
| A52412 |  | Installation of Bus Duct System | 20d | 2019-08-04 | 2019-08-26 | A52032 | 108d | 52d | Electrical Crew [200 h] | 18.86 | MEP | 1 | MB |  |  |
| A51972 |  | Power Cable Laying | 25d | 2019-08-26 | 2019-09-18 | A52352, A51992 | 49.5d | 0d | Electrical Crew [250 h] | 23.58 | MEP | 1 | MB | 1600 | CON |
| A51982 |  | Continuity Test - Power Cables | 4d | 2019-09-18 | 2019-09-22 | A51972 | 79d | 23d | Electrical Crew [40 h] | 3.77 | MEP | 1 | MB | 1601 | CON |
| A52362 |  | Installation of Central Battery Equipment | 6d | 2019-09-18 | 2019-09-25 | A51972, A52352 | 77d | 21d | Electrical Crew [60 h] | 5.66 | MEP | 1 | MB |  |  |
| A52372 |  | Installation of Disconnect Switch | 8d | 2019-09-18 | 2019-09-28 | A51972, A52352 | 75d | 19d | Electrical Crew [80 h] | 7.54 | MEP | 1 | MB |  |  |
| A52392 |  | Installation of Switch Boards (MDB, EMDB) | 15d | 2019-09-18 | 2019-10-03 | A51972, A52352 | 49.5d | 0d | Electrical Crew [150 h] | 14.15 | MEP | 1 | MB |  |  |
| A52402 |  | Installation of Panel Boards | 15d | 2019-09-18 | 2019-10-03 | A51972, A52352 | 49.5d | 0d | Electrical Crew [150 h] | 14.15 | MEP | 1 | MB |  |  |
| A52422 |  | Installation of MCC | 15d | 2019-09-18 | 2019-10-03 | A51972, A52352 | 49.5d | 0d | Electrical Crew [150 h] | 14.15 | MEP | 1 | MB |  |  |
| A52432 |  | Installation of Lighting Control System | 12d | 2019-09-18 | 2019-10-01 | A51972, A52352 | 52.5d | 3d | Electrical Crew [120 h] | 11.32 | MEP | 1 | MB |  |  |
| A52382 |  | Installation of Wiring Devices and Outlets | 12d | 2019-10-03 | 2019-10-15 | A52352, A52422, A52402, A52392, A52432 | 49.5d | 0d | Electrical Crew [120 h] | 11.32 | MEP | 1 | MB |  |  |

| ID | WBS | Activity | Duration | Start | Finish | Predecessors | Total float | Free float | Resources | Cost | Discipline | AREA | LOCATION | MSP Activity ID | MEP-Phase |
| --- | --- | --- | --- | --- | --- | --- | --- | --- | --- | --- | --- | --- | --- | --- | --- |
|  | 1.4.1.4.1.1.4.1.3.-2 | **Elec._Final Fix** |  | 2019-10-03 | 2019-10-31 |  |  |  |  |  |  |  |  |  |  |
| A52442 |  | Panel Board Termination | 8d | 2019-10-03 | 2019-10-12 | A52392, A52402, A52422 | 66d | 11.5d | Electrical Crew [80 h] | 7.54 | MEP | 1 | MB |  |  |
| A52012 |  | Wiring devices Termination | 6d | 2019-10-15 | 2019-10-21 | A52362, A52372, A52412, A52432, A52382, A51982 | 56d | 1.5d | Electrical Crew [60 h] | 5.66 | MEP | 1 | MB | 1617 | CON |
| A52002 |  | Lighting Fixtures Installation and Termination | 10d | 2019-10-22 | 2019-10-31 | A51972, A52352, A52442, A52012, 1F5-FNS-B04-1060 | 54.5d | 40d | Electrical Crew [100 h] | 9.43 | MEP | 1 | MB | 1616 | CON |
|  | 1.4.1.4.1.1.4.1.4 | **FIRE FIGHTING SYSTEM** |  | 2019-07-06 | 2019-11-14 |  |  |  |  |  |  |  |  |  |  |
|  | 1.4.1.4.1.1.4.1.4.1. | **1st Fix** |  | 2019-07-06 | 2019-08-19 |  |  |  |  |  |  |  |  |  |  |
| A52102 |  | Fire Fighting Hangers & Supports | 15d | 2019-07-06 | 2019-07-18 | RM140 | 78.5d | 0d | Fire Fighting Crew [150 h] | 14.15 | MEP | 1 | MB | 1622 | CON |
| A52072 |  | Pipe Installation | 30d | 2019-07-20 | 2019-08-19 | A52102 | 78.5d | 0d | FF pipe [206 Limt]; FIRE FIGHTING [361 h] | 34.04 | MEP | 1 | MB | 1625 | CON |
|  | 1.4.1.4.1.1.4.1.4.-1 | **2nd Fix** |  | 2019-08-20 | 2019-09-16 |  |  |  |  |  |  |  |  |  |  |
| A52082 |  | Valve and Accessories Installation | 20d | 2019-08-20 | 2019-09-07 | A52072, A52102 | 78.5d | 0d | Fire Fighting Crew [200 h] | 18.86 | MEP | 1 | MB | 1627 | CON |
| A52092 |  | Leak Test | 10d | 2019-09-08 | 2019-09-16 | A52082 | 78.5d | 29d | Fire Fighting Crew [100 h] | 9.43 | MEP | 1 | MB | 1631 | CON |
|  | 1.4.1.4.1.1.4.1.4.-2 | **FF_Final Fix** |  | 2019-10-22 | 2019-11-14 |  |  |  |  |  |  |  |  |  |  |
| A52112 |  | Installation of Sprinklers | 15d | 2019-10-22 | 2019-11-05 | A52072, A52082, A52092, 1F5-FNS-B04-1060 | 49.5d | 0d | Fire Fighting Crew [150 h] | 14.15 | MEP | 1 | MB | 1633 | CON |
| A52122 |  | Instalaltion of Fire Extinguisher | 10d | 2019-11-05 | 2019-11-14 | A52072, A52112, A52452 FF, LOE-SUM3-270 FF | 104.5d | 105d | Fire Fighting Crew [100 h] | 9.43 | MEP | 1 | MB |  | CON |
| A52452 |  | Installation of Fire hose Cabinet | 5d | 2019-11-05 | 2019-11-10 | A52072, A52112 | 109.5d | 5d | Fire Fighting Crew [50 h] | 4.71 | MEP | 1 | MB |  |  |
|  | 5 | **B04 - TECHINICAL ZONE 02** |  | 2019-06-16 | 2019-10-26 |  |  |  |  |  |  |  |  |  |  |
|  | 1.4.1.4.1.1.4.1.1 | **HVAC SYSTEM** |  | 2019-06-16 | 2019-10-16 |  |  |  |  |  |  |  |  |  |  |
|  | 1.4.1.4.1.1.4.1.1.1. | **1st Fix** |  | 2019-06-16 | 2019-07-02 |  |  |  |  |  |  |  |  |  |  |
| A49902 |  | Hanger and support Installation - Duct | 6d | 2019-06-16 | 2019-06-20 | RM130 | 134.75d | 0d | Mechanical Crew [60 h] | 5.66 | MEP | 2 | MB | 1546 | CON |
| A49972 |  | Hanger and support Installation - CHW | 6d | 2019-06-16 | 2019-06-20 | A49902 SS | 134.75d | 0d | Mechanical Crew [60 h] | 5.66 | MEP | 2 | MB |  |  |
| A49882 |  | Duct Installation | 12d | 2019-06-17 | 2019-06-29 | A49902 SS+2d | 145.25d | 0d | Duct Installation [260 Sqmt]; HVAC [780 h] | 73.55 | MEP | 2 | MB | 1549 | CON |
| A49892 |  | Duct Insulation | 8d | 2019-06-20 | 2019-06-27 | A49882 SS+3d | 169.25d | 98.5d | Duct Insulation [263 Sqmt]; HVAC [190 h] | 17.92 | MEP | 2 | MB | 1552 | CON |
| A49992 |  | Chilled Water Piping Installation | 12d | 2019-06-20 | 2019-07-02 | A49972 | 134.75d | 0d | Mechanical Crew [120 h] | 11.32 | MEP | 2 | MB |  |  |
|  | 1.4.1.4.1.1.4.1.1.-1 | **2nd Fix** |  | 2019-06-29 | 2019-07-21 |  |  |  |  |  |  |  |  |  |  |
| A49982 |  | Installation of Duct Accessories (VD, FD, MSD etc....) | 12d | 2019-06-29 | 2019-07-09 | A49882 | 156.25d | 85.5d | Mechanical Crew [120 h] | 11.32 | MEP | 2 | MB |  |  |
| A50082 |  | CRAC Units Installation | 15d | 2019-06-29 | 2019-07-13 | A49882 | 145.25d | 9d | Mechanical Crew [150 h] | 14.15 | MEP | 2 | MB |  |  |
| A50092 |  | FCU Installation | 15d | 2019-06-29 | 2019-07-13 | A49882 | 145.25d | 9d | Mechanical Crew [150 h] | 14.15 | MEP | 2 | MB |  |  |
| A50102 |  | VRF DX Units Installation | 12d | 2019-06-29 | 2019-07-09 | A49882 | 148.25d | 12d | Mechanical Crew [120 h] | 11.32 | MEP | 2 | MB |  |  |
| A50112 |  | Installation of Attenuators | 10d | 2019-06-29 | 2019-07-08 | A49882 | 150.25d | 14d | Mechanical Crew [100 h] | 9.43 | MEP | 2 | MB |  |  |
| A50122 |  | Installation of HVAC Fans | 10d | 2019-06-29 | 2019-07-08 | A49882 | 150.25d | 14d | Mechanical Crew [100 h] | 9.43 | MEP | 2 | MB |  |  |
| A50142 |  | Pressurization Unit | 8d | 2019-06-29 | 2019-07-06 | A49882 | 152.25d | 16d | Mechanical Crew [80 h] | 7.54 | MEP | 2 | MB |  |  |
| A50152 |  | Dosing pot | 5d | 2019-06-29 | 2019-07-03 | A49882 | 155.25d | 19d | Mechanical Crew [50 h] | 4.71 | MEP | 2 | MB |  |  |
| A50172 |  | Air Handling Units Installation | 12d | 2019-06-29 | 2019-07-09 | A49882 | 148.25d | 12d | Mechanical Crew [120 h] | 11.32 | MEP | 2 | MB |  |  |
| A50012 |  | Valves and Accessories | 10d | 2019-07-02 | 2019-07-11 | A49992 | 134.75d | 0d | Mechanical Crew [100 h] | 9.43 | MEP | 2 | MB |  |  |
| A50132 |  | Air-Cooled Chillers | 15d | 2019-07-02 | 2019-07-16 | A49992 | 141.25d | 5d | Mechanical Crew [150 h] | 14.15 | MEP | 2 | MB |  |  |
| A50182 |  | Chilled Water Pump Installation | 12d | 2019-07-02 | 2019-07-13 | A49992 | 144.25d | 8d | Mechanical Crew [120 h] | 11.32 | MEP | 2 | MB |  |  |
| A50022 |  | Chilled Water Pipe Insulation and Cladding | 10d | 2019-07-11 | 2019-07-21 | A49992, A50012 | 134.75d | 0d | Mechanical Crew [100 h] | 9.43 | MEP | 2 | MB |  |  |

| ID | WBS | Activity | Duration | Start | Finish | Predecessors | Total float | Free float | Resources | Cost | Discipline | AREA | LOCATION | MSP Activity ID | MEP-Phase |
| --- | --- | --- | --- | --- | --- | --- | --- | --- | --- | --- | --- | --- | --- | --- | --- |
|  | 1.4.1.4.1.1.4.1.1.-2 | **HVAC_Final Fix** |  | 2019-07-21 | 2019-10-16 |  |  |  |  |  |  |  |  |  |  |
| A50162 |  | Equuipment Connection | 8d | 2019-07-21 | 2019-07-28 | A50182, A50172, A50132, A50122, A50112, A50082, A50092, A50102, A50152, A50142, A50022 | 136.25d | 65.5d | Mechanical Crew [80 h] | 7.54 | MEP | 2 | MB |  |  |
| A50002 |  | Air Outlets (Grills, Diffusers, Registers etc...) | 15d | 2019-10-02 | 2019-10-16 | A49982, A49882, A49892, A50162, 1F5-FNS-B04-840 | 70.75d | 61.25d | Mechanical Crew [150 h] | 14.15 | MEP | 2 | MB |  |  |
|  | 1.4.1.4.1.1.4.1.2 | **PLUMBING SYSTEM** |  | 2019-06-16 | 2019-10-10 |  |  |  |  |  |  |  |  |  |  |
|  | 1.4.1.4.1.1.4.1.2.1. | **1st Fix** |  | 2019-06-16 | 2019-07-09 |  |  |  |  |  |  |  |  |  |  |
| A49762 |  | Hanger and support Installation | 10d | 2019-06-16 | 2019-06-24 | RM130 | 130.75d | 0d | Plumbing Crew [100 h] | 9.43 | MEP | 2 | MB | 1566 | CON |
| A49802 |  | Drainage and Vent Pipe & Fittings | 20d | 2019-06-20 | 2019-07-08 | A49762 SS+5d | 165.25d | 1d | Plumbing Crew [200 h] | 18.86 | MEP | 2 | MB | 1573 | CON |
| A49772 |  | Domestic Water Pipe & Fittings | 20d | 2019-06-20 | 2019-07-09 | A49762 SS+6d | 130.75d | 0d | Plumbing Crew [200 h] | 18.86 | MEP | 2 | MB | 1570 | CON |
|  | 1.4.1.4.1.1.4.1.2.-1 | **2nd Fix** |  | 2019-07-09 | 2019-07-24 |  |  |  |  |  |  |  |  |  |  |
| A49782 |  | Domestic Water Valves | 12d | 2019-07-09 | 2019-07-21 | A49772 | 130.75d | 0d | Plumbing Crew [120 h] | 11.32 | MEP | 2 | MB | 1571 | CON |
| A50042 |  | Sewege Pumps Installation | 5d | 2019-07-09 | 2019-07-14 | A49802, A49772 | 164.25d | 88d | Plumbing Crew [50 h] | 4.71 | MEP | 2 | MB |  |  |
| A49792 |  | Leak Test | 4d | 2019-07-21 | 2019-07-24 | A49782 | 130.75d | 62d | Plumbing Crew [40 h] | 3.77 | MEP | 2 | MB | 1572 | CON |
|  | 1.4.1.4.1.1.4.1.2.-2 | **PLM_Final Fix** |  | 2019-10-09 | 2019-10-10 |  |  |  |  |  |  |  |  |  |  |
| A50032 |  | Water Heaters | 2d | 2019-10-09 | 2019-10-10 | A49792, A49802, A49772, 1F5-FNS-B04-850 | 76.25d | 0d | Plumbing Crew [20 h] | 1.89 | MEP | 2 | MB |  |  |
| A50052 |  | Floor Drain | 2d | 2019-10-09 | 2019-10-10 | A50032 SS | 76.25d | 0d | Plumbing Crew [20 h] | 1.89 | MEP | 2 | MB |  |  |
| A50062 |  | Wash Basin / Water Closet | 2d | 2019-10-09 | 2019-10-10 | A50052 SS | 76.25d | 0d | Plumbing Crew [20 h] | 1.89 | MEP | 2 | MB |  |  |
| A50072 |  | Eye Wash | 2d | 2019-10-09 | 2019-10-10 | A50062 SS, A50042 | 76.25d | 53.75d | Plumbing Crew [20 h] | 1.89 | MEP | 2 | MB |  |  |
|  | 1.4.1.4.1.1.4.1.3 | **ELECTRICAL / CONTROLS** |  | 2019-06-16 | 2019-10-12 |  |  |  |  |  |  |  |  |  |  |
|  | 1.4.1.4.1.1.4.1.3.1. | **1st Fix** |  | 2019-06-16 | 2019-07-15 |  |  |  |  |  |  |  |  |  |  |
| A49862 |  | Installation of Conduits and Boxes | 12d | 2019-06-16 | 2019-06-26 | RM130 | 68.75d | 0d | Electrical Crew [120 h] | 11.32 | MEP | 2 | MB | 1592 | CON |
| A49872 |  | Installation of Cable Tray, Ladder and Trunk | 20d | 2019-06-26 | 2019-07-15 | A49862 | 129.25d | 0d | Electrical Crew [200 h] | 18.86 | MEP | 2 | MB | 1593 | CON |
|  | 1.4.1.4.1.1.4.1.3.-1 | **2nd Fix** |  | 2019-06-26 | 2019-09-25 |  |  |  |  |  |  |  |  |  |  |
| A49832 |  | Grounding and Bonding Installation | 20d | 2019-06-26 | 2019-07-15 | A49862 | 68.75d | 0d | Electrical Crew [200 h] | 18.86 | MEP | 2 | MB | 1596 | CON |
| A50192 |  | Wire Pulling | 20d | 2019-07-15 | 2019-08-03 | A49832 | 68.75d | 0d | Electrical Crew [200 h] | 18.86 | MEP | 2 | MB |  |  |
| A50252 |  | Installation of Bus Duct System | 20d | 2019-07-15 | 2019-08-03 | A49872 | 129.25d | 52d | Electrical Crew [200 h] | 18.86 | MEP | 2 | MB |  |  |
| A49812 |  | Power Cable Laying | 25d | 2019-08-03 | 2019-08-29 | A50192, A49832 | 68.75d | 0d | Electrical Crew [250 h] | 23.58 | MEP | 2 | MB | 1600 | CON |
| A49822 |  | Continuity Test - Power Cables | 4d | 2019-08-29 | 2019-09-02 | A49812 | 100.25d | 23d | Electrical Crew [40 h] | 3.77 | MEP | 2 | MB | 1601 | CON |
| A50202 |  | Installation of Central Battery Equipment | 6d | 2019-08-29 | 2019-09-04 | A49812, A50192 | 98.25d | 21d | Electrical Crew [60 h] | 5.66 | MEP | 2 | MB |  |  |
| A50212 |  | Installation of Disconnect Switch | 8d | 2019-08-29 | 2019-09-05 | A49812, A50192 | 96.25d | 19d | Electrical Crew [80 h] | 7.54 | MEP | 2 | MB |  |  |
| A50232 |  | Installation of Switch Boards (MDB, EMDB) | 15d | 2019-08-29 | 2019-09-12 | A49812, A50192 | 68.75d | 0d | Electrical Crew [150 h] | 14.15 | MEP | 2 | MB |  |  |
| A50242 |  | Installation of Panel Boards | 15d | 2019-08-29 | 2019-09-12 | A49812, A50192 | 68.75d | 0d | Electrical Crew [150 h] | 14.15 | MEP | 2 | MB |  |  |
| A50262 |  | Installation of MCC | 15d | 2019-08-29 | 2019-09-12 | A49812, A50192 | 68.75d | 0d | Electrical Crew [150 h] | 14.15 | MEP | 2 | MB |  |  |
| A50272 |  | Installation of Lighting Control System | 12d | 2019-08-29 | 2019-09-10 | A49812, A50192 | 71.75d | 3d | Electrical Crew [120 h] | 11.32 | MEP | 2 | MB |  |  |
| A50222 |  | Installation of Wiring Devices and Outlets | 12d | 2019-09-12 | 2019-09-25 | A50192, A50262, A50242, A50232, A50272 | 68.75d | 0d | Electrical Crew [120 h] | 11.32 | MEP | 2 | MB |  |  |

| ID | WBS | Activity | Type | Duration | Start | Finish | Predecessors | Total float | Free float | Calendar | Resources | Cost | Discipline | AREA | LOCATION | MSP Activity ID | MEP-Phase |
| --- | --- | --- | --- | --- | --- | --- | --- | --- | --- | --- | --- | --- | --- | --- | --- | --- | --- |
|  | 1.4.1.4.1.1.4.1.3.-2 | **Elec._Final Fix** |  |  | 2019-09-12 | 2019-10-12 |  |  |  |  |  |  |  |  |  |  |  |
| A50282 |  | Panel Board Termination |  | 8d | 2019-09-12 | 2019-09-19 | A50232, A50242, A50262 | 87.25d | 11.5d |  | Electrical Crew [80 h] | 7.54 | MEP | 2 | MB |  |  |
| A49852 |  | Wiring devices Termination |  | 6d | 2019-09-25 | 2019-10-01 | A50202, A50212, A50252, A50272, A50222, A49822 | 77.25d | 1.5d |  | Electrical Crew [60 h] | 5.66 | MEP | 2 | MB | 1617 | CON |
| A49842 |  | Lighting Fixtures Installation and Termination |  | 10d | 2019-10-02 | 2019-10-12 | A49812, A50192, A50282, A49852, 1F5-FNS-B04-840 | 75.75d | 61.25d |  | Electrical Crew [100 h] | 9.43 | MEP | 2 | MB | 1616 | CON |
|  | 1.4.1.4.1.1.4.1.4 | **FIRE FIGHTING SYSTEM** |  |  | 2019-06-16 | 2019-10-26 |  |  |  |  |  |  |  |  |  |  |  |
|  | 1.4.1.4.1.1.4.1.4.1. | **1st Fix** |  |  | 2019-06-16 | 2019-07-27 |  |  |  |  |  |  |  |  |  |  |  |
| A49942 |  | Fire Fighting Hangers & Supports |  | 15d | 2019-06-16 | 2019-06-29 | RM130 | 97.75d | 0d |  | Fire Fighting Crew [150 h] | 14.15 | MEP | 2 | MB | 1622 | CON |
| A49912 |  | Pipe Installation |  | 30d | 2019-06-30 | 2019-07-27 | A49942 | 97.75d | 0d |  | FIRE FIGHTING [361 h]; FF pipe [206 Limt] | 34.04 | MEP | 2 | MB | 1625 | CON |
|  | 1.4.1.4.1.1.4.1.4.-1 | **2nd Fix** |  |  | 2019-07-28 | 2019-08-27 |  |  |  |  |  |  |  |  |  |  |  |
| A49922 |  | Valve and Accessories Installation |  | 20d | 2019-07-28 | 2019-08-18 | A49912, A49942 | 97.75d | 0d |  | Fire Fighting Crew [200 h] | 18.86 | MEP | 2 | MB | 1627 | CON |
| A49932 |  | Leak Test |  | 10d | 2019-08-19 | 2019-08-27 | A49922 | 97.75d | 29d |  | Fire Fighting Crew [100 h] | 9.43 | MEP | 2 | MB | 1631 | CON |
|  | 1.4.1.4.1.1.4.1.4.-2 | **FF_Final Fix** |  |  | 2019-10-02 | 2019-10-26 |  |  |  |  |  |  |  |  |  |  |  |
| A49952 |  | Installation of Sprinklers |  | 15d | 2019-10-02 | 2019-10-16 | A49912, A49922, A49932, 1F5-FNS-B04-840 | 70.75d | 0d |  | Fire Fighting Crew [150 h] | 14.15 | MEP | 2 | MB | 1633 | CON |
| A49962 |  | Instalaltion of Fire Extinguisher |  | 10d | 2019-10-16 | 2019-10-26 | A49912, A49952, A50292 FF | 125.75d | 126.25d |  | Fire Fighting Crew [100 h] | 9.43 | MEP | 2 | MB |  | CON |
| A50292 |  | Installation of Fire hose Cabinet |  | 5d | 2019-10-16 | 2019-10-21 | A49912, A49952 | 130.75d | 5d |  | Fire Fighting Crew [50 h] | 4.71 | MEP | 2 | MB |  |  |
|  | 1.4.31 | **B03 - CONCOURSE** |  |  | 2019-03-18 | 2019-11-27 |  |  |  |  |  |  |  |  |  |  |  |
|  | 7 | **SOUTH CONCOURSE - ZONE 4 AND 5** |  |  | 2019-03-18 | 2019-09-15 |  |  |  |  |  |  |  |  |  |  |  |
| LOE-SUM3-280 |  | South . B03 - MEP Works; 1st & 2nd Fix | level of effort | 161.5d | 2019-03-18 | 2019-08-15 | RM160 | 114.25d | 0d | Saudi |  |  | MEP |  |  |  |  |
| LOE-SUM3-290 |  | South . B03 - MEP Works; Final fix | level of effort | 156d | 2019-04-22 | 2019-09-15 | LOE-SUM3-280, A56642 SS | 169.75d | 0d | Saudi |  |  | MEP |  |  |  |  |
|  | 1 | **B03 - CONCOURSE ZONE 04** |  |  | 2019-05-04 | 2019-09-15 |  |  |  |  |  |  |  |  |  |  |  |
|  | 1.4.1.4.1.1.4.1.1 | **HVAC SYSTEM** |  |  | 2019-05-04 | 2019-09-05 |  |  |  |  |  |  |  |  |  |  |  |
|  | 1.4.1.4.1.1.4.1.1.1. | **1st Fix** |  |  | 2019-05-04 | 2019-05-20 |  |  |  |  |  |  |  |  |  |  |  |
| A54222 |  | Hanger and support Installation - Duct |  | 6d | 2019-05-04 | 2019-05-08 | RM150 | 162.25d | 0d |  | Mechanical Crew [60 h] | 5.66 | MEP | 4 | MB | 1546 | CON |
| A54292 |  | Hanger and support Installation - CHW |  | 6d | 2019-05-04 | 2019-05-08 | A54222 SS | 162.25d | 0d |  | Mechanical Crew [60 h] | 5.66 | MEP | 4 | MB |  |  |
| A54202 |  | Duct Installation |  | 12d | 2019-05-05 | 2019-05-16 | A54222 SS+2d | 187.75d | 0d |  | Duct Installation [260 Sqmt]; HVAC [780 h] | 73.55 | MEP | 4 | MB | 1549 | CON |
| A54212 |  | Duct Insulation |  | 8d | 2019-05-08 | 2019-05-15 | A54202 SS+3d | 211.75d | 98.5d |  | Duct Insulation [263 Sqmt]; HVAC [190 h] | 17.92 | MEP | 4 | MB | 1552 | CON |
| A54312 |  | Chilled Water Piping Installation |  | 12d | 2019-05-08 | 2019-05-20 | A54292 | 162.25d | 0d |  | Mechanical Crew [120 h] | 11.32 | MEP | 4 | MB |  |  |

| ID | WBS | Activity | Duration | Start | Finish | Predecessors | Total float | Free float | Resources | Cost | Discipline | AREA | LOCATION | MSP Activity ID | MEP-Phase |
| --- | --- | --- | --- | --- | --- | --- | --- | --- | --- | --- | --- | --- | --- | --- | --- |
|  | 1.4.1.4.1.1.4.1.1.-1 | **2nd Fix** |  | 2019-05-16 | 2019-06-11 |  |  |  |  |  |  |  |  |  |  |
| A54302 |  | Installation of Duct Accessories (VD, FD, MSD etc....) | 12d | 2019-05-16 | 2019-05-27 | A54202 | 198.75d | 85.5d | Mechanical Crew [120 h] | 11.32 | MEP | 4 | MB |  |  |
| A54402 |  | CRAC Units Installation | 15d | 2019-05-16 | 2019-05-30 | A54202 | 187.75d | 9d | Mechanical Crew [150 h] | 14.15 | MEP | 4 | MB |  |  |
| A54412 |  | FCU Installation | 15d | 2019-05-16 | 2019-05-30 | A54202 | 187.75d | 9d | Mechanical Crew [150 h] | 14.15 | MEP | 4 | MB |  |  |
| A54422 |  | VRF DX Units Installation | 12d | 2019-05-16 | 2019-05-27 | A54202 | 190.75d | 12d | Mechanical Crew [120 h] | 11.32 | MEP | 4 | MB |  |  |
| A54432 |  | Installation of Attenuators | 10d | 2019-05-16 | 2019-05-26 | A54202 | 192.75d | 14d | Mechanical Crew [100 h] | 9.43 | MEP | 4 | MB |  |  |
| A54442 |  | Installation of HVAC Fans | 10d | 2019-05-16 | 2019-05-26 | A54202 | 192.75d | 14d | Mechanical Crew [100 h] | 9.43 | MEP | 4 | MB |  |  |
| A54462 |  | Pressurization Unit | 8d | 2019-05-16 | 2019-05-23 | A54202 | 194.75d | 16d | Mechanical Crew [80 h] | 7.54 | MEP | 4 | MB |  |  |
| A54472 |  | Dosing pot | 5d | 2019-05-16 | 2019-05-21 | A54202 | 197.75d | 19d | Mechanical Crew [50 h] | 4.71 | MEP | 4 | MB |  |  |
| A54492 |  | Air Handling Units Installation | 12d | 2019-05-16 | 2019-05-27 | A54202 | 190.75d | 12d | Mechanical Crew [120 h] | 11.32 | MEP | 4 | MB |  |  |
| A54332 |  | Valves and Accessories | 10d | 2019-05-20 | 2019-05-29 | A54312 | 162.25d | 0d | Mechanical Crew [100 h] | 9.43 | MEP | 4 | MB |  |  |
| A54452 |  | Air-Cooled Chillers | 15d | 2019-05-20 | 2019-06-03 | A54312 | 183.75d | 5d | Mechanical Crew [150 h] | 14.15 | MEP | 4 | MB |  |  |
| A54502 |  | Chilled Water Pump Installation | 12d | 2019-05-20 | 2019-05-30 | A54312 | 186.75d | 8d | Mechanical Crew [120 h] | 11.32 | MEP | 4 | MB |  |  |
| A54342 |  | Chilled Water Pipe Insulation and Cladding | 10d | 2019-05-29 | 2019-06-11 | A54312, A54332 | 162.25d | 0d | Mechanical Crew [100 h] | 9.43 | MEP | 4 | MB |  |  |
|  | 1.4.1.4.1.1.4.1.1.-2 | **HVAC_Final Fix** |  | 2019-06-11 | 2019-09-05 |  |  |  |  |  |  |  |  |  |  |
| A54482 |  | Equuipment Connection | 8d | 2019-06-11 | 2019-06-18 | A54502, A54492, A54452, A54442, A54432, A54402, A54412, A54422, A54472, A54462, A54342 | 178.75d | 65.5d | Mechanical Crew [80 h] | 7.54 | MEP | 4 | MB |  |  |
| A54322 |  | Air Outlets (Grills, Diffusers, Registers etc...) | 15d | 2019-08-22 | 2019-09-05 | A54302, A54202, A54212, A54482, 1F5-FNS-B03-230 | 113.25d | 103.75d | Mechanical Crew [150 h] | 14.15 | MEP | 4 | MB |  |  |
|  | 1.4.1.4.1.1.4.1.2 | **PLUMBING SYSTEM** |  | 2019-05-04 | 2019-08-31 |  |  |  |  |  |  |  |  |  |  |
|  | 1.4.1.4.1.1.4.1.2.1. | **1st Fix** |  | 2019-05-04 | 2019-05-27 |  |  |  |  |  |  |  |  |  |  |
| A54082 |  | Hanger and support Installation | 10d | 2019-05-04 | 2019-05-12 | RM150 | 158.25d | 0d | Plumbing Crew [100 h] | 9.43 | MEP | 4 | MB | 1566 | CON |
| A54122 |  | Drainage and Vent Pipe & Fittings | 20d | 2019-05-08 | 2019-05-26 | A54082 SS+5d | 207.75d | 1d | Plumbing Crew [200 h] | 18.86 | MEP | 4 | MB | 1573 | CON |
| A54092 |  | Domestic Water Pipe & Fittings | 20d | 2019-05-08 | 2019-05-27 | A54082 SS+6d | 158.25d | 0d | Plumbing Crew [200 h] | 18.86 | MEP | 4 | MB | 1570 | CON |
|  | 1.4.1.4.1.1.4.1.2.-1 | **2nd Fix** |  | 2019-05-27 | 2019-06-15 |  |  |  |  |  |  |  |  |  |  |
| A54102 |  | Domestic Water Valves | 12d | 2019-05-27 | 2019-06-11 | A54092 | 158.25d | 0d | Plumbing Crew [120 h] | 11.32 | MEP | 4 | MB | 1571 | CON |
| A54362 |  | Sewege Pumps Installation | 5d | 2019-05-27 | 2019-06-01 | A54122, A54092 | 206.75d | 88d | Plumbing Crew [50 h] | 4.71 | MEP | 4 | MB |  |  |
| A54112 |  | Leak Test | 4d | 2019-06-11 | 2019-06-15 | A54102 | 158.25d | 62d | Plumbing Crew [40 h] | 3.77 | MEP | 4 | MB | 1572 | CON |

| ID | WBS | Activity | Duration | Start | Finish | Predecessors | Total float | Free float | Resources | Cost | Discipline | AREA | LOCATION | MSP Activity ID | MEP-Phase |
| --- | --- | --- | --- | --- | --- | --- | --- | --- | --- | --- | --- | --- | --- | --- | --- |
|  | 1.4.1.4.1.1.4.1.2.-2 | **PLM_Final Fix** |  | 2019-08-29 | 2019-08-31 |  |  |  |  |  |  |  |  |  |  |
| A54352 |  | Water Heaters | 2d | 2019-08-29 | 2019-08-31 | A54112, A54122, A54092, 1F5-FNS-B03-240 | 118.75d | 0d | Plumbing Crew [20 h] | 1.89 | MEP | 4 | MB |  |  |
| A54372 |  | Floor Drain | 2d | 2019-08-29 | 2019-08-31 | A54352 SS | 118.75d | 0d | Plumbing Crew [20 h] | 1.89 | MEP | 4 | MB |  |  |
| A54382 |  | Wash Basin / Water Closet | 2d | 2019-08-29 | 2019-08-31 | A54372 SS | 118.75d | 0d | Plumbing Crew [20 h] | 1.89 | MEP | 4 | MB |  |  |
| A54392 |  | Eye Wash | 2d | 2019-08-29 | 2019-08-31 | A54382 SS, A54362 | 118.75d | 96.25d | Plumbing Crew [20 h] | 1.89 | MEP | 4 | MB |  |  |
|  | 1.4.1.4.1.1.4.1.3 | **ELECTRICAL / CONTROLS** |  | 2019-05-04 | 2019-09-01 |  |  |  |  |  |  |  |  |  |  |
|  | 1.4.1.4.1.1.4.1.3.1. | **1st Fix** |  | 2019-05-04 | 2019-06-02 |  |  |  |  |  |  |  |  |  |  |
| A54182 |  | Installation of Conduits and Boxes | 12d | 2019-05-04 | 2019-05-14 | RM150 | 47d | 0d | Electrical Crew [120 h] | 11.32 | MEP | 4 | MB | 1592 | CON |
| A54192 |  | Installation of Cable Tray, Ladder and Trunk | 20d | 2019-05-14 | 2019-06-02 | A54182 | 171.75d | 0d | Electrical Crew [200 h] | 18.86 | MEP | 4 | MB | 1593 | CON |
|  | 1.4.1.4.1.1.4.1.3.-1 | **2nd Fix** |  | 2019-05-14 | 2019-08-15 |  |  |  |  |  |  |  |  |  |  |
| A54152 |  | Grounding and Bonding Installation | 20d | 2019-05-14 | 2019-06-02 | A54182 | 47d | 0d | Electrical Crew [200 h] | 18.86 | MEP | 4 | MB | 1596 | CON |
| A54512 |  | Wire Pulling | 20d | 2019-06-02 | 2019-06-24 | A54152 | 47d | 0d | Electrical Crew [200 h] | 18.86 | MEP | 4 | MB |  |  |
| A54572 |  | Installation of Bus Duct System | 20d | 2019-06-02 | 2019-06-24 | A54192 | 171.75d | 52d | Electrical Crew [200 h] | 18.86 | MEP | 4 | MB |  |  |
| A54132 |  | Power Cable Laying | 25d | 2019-06-24 | 2019-07-17 | A54512, A54152 | 47d | 0d | Electrical Crew [250 h] | 23.58 | MEP | 4 | MB | 1600 | CON |
| A54142 |  | Continuity Test - Power Cables | 4d | 2019-07-17 | 2019-07-21 | A54132 | 142.75d | 23d | Electrical Crew [40 h] | 3.77 | MEP | 4 | MB | 1601 | CON |
| A54522 |  | Installation of Central Battery Equipment | 6d | 2019-07-17 | 2019-07-23 | A54132, A54512 | 140.75d | 21d | Electrical Crew [60 h] | 5.66 | MEP | 4 | MB |  |  |
| A54532 |  | Installation of Disconnect Switch | 8d | 2019-07-17 | 2019-07-24 | A54132, A54512 | 138.75d | 19d | Electrical Crew [80 h] | 7.54 | MEP | 4 | MB |  |  |
| A54552 |  | Installation of Switch Boards (MDB, EMDB) | 15d | 2019-07-17 | 2019-07-31 | A54132, A54512 | 47d | 0d | Electrical Crew [150 h] | 14.15 | MEP | 4 | MB |  |  |
| A54562 |  | Installation of Panel Boards | 15d | 2019-07-17 | 2019-07-31 | A54132, A54512 | 47d | 0d | Electrical Crew [150 h] | 14.15 | MEP | 4 | MB |  |  |
| A54582 |  | Installation of MCC | 15d | 2019-07-17 | 2019-07-31 | A54132, A54512 | 47d | 0d | Electrical Crew [150 h] | 14.15 | MEP | 4 | MB |  |  |
| A54592 |  | Installation of Lighting Control System | 12d | 2019-07-17 | 2019-07-29 | A54132, A54512 | 50d | 3d | Electrical Crew [120 h] | 11.32 | MEP | 4 | MB |  |  |
| A54542 |  | Installation of Wiring Devices and Outlets | 12d | 2019-07-31 | 2019-08-15 | A54512, A54582, A54562, A54552, A54592 | 47d | 0d | Electrical Crew [120 h] | 11.32 | MEP | 4 | MB |  |  |
|  | 1.4.1.4.1.1.4.1.3.-2 | **Elec._Final Fix** |  | 2019-07-31 | 2019-09-01 |  |  |  |  |  |  |  |  |  |  |
| A54602 |  | Panel Board Termination | 8d | 2019-07-31 | 2019-08-07 | A54552, A54562, A54582 | 129.75d | 11.5d | Electrical Crew [80 h] | 7.54 | MEP | 4 | MB |  |  |
| A54172 |  | Wiring devices Termination | 6d | 2019-08-15 | 2019-08-20 | A54522, A54532, A54572, A54592, A54542, A54142 | 119.75d | 1.5d | Electrical Crew [60 h] | 5.66 | MEP | 4 | MB | 1617 | CON |
| A54162 |  | Lighting Fixtures Installation and Termination | 10d | 2019-08-22 | 2019-09-01 | A54132, A54512, A54602, A54172, 1F5-FNS-B03-230, LOE-SUM3-290 FF | 118.25d | 103.75d | Electrical Crew [100 h] | 9.43 | MEP | 4 | MB | 1616 | CON |

| ID | WBS | Activity | Duration | Start | Finish | Predecessors | Total float | Free float | Resources | Cost | MSP Activity ID | Discipline | MEP-Phase | AREA | LOCATION |
| --- | --- | --- | --- | --- | --- | --- | --- | --- | --- | --- | --- | --- | --- | --- | --- |
|  | 1.4.1.4.1.1.4.1.4 | **FIRE FIGHTING SYSTEM** |  | 2019-05-04 | 2019-09-15 |  |  |  |  |  |  |  |  |  |  |
|  | 1.4.1.4.1.1.4.1.4.1. | **1st Fix** |  | 2019-05-04 | 2019-06-17 |  |  |  |  |  |  |  |  |  |  |
| A54262 |  | Fire Fighting Hangers & Supports | 15d | 2019-05-04 | 2019-05-16 | RM150 | 125.25d | 0d | Fire Fighting Crew [150 h] | 14.15 | 1622 | MEP | CON | 4 | MB |
| A54232 |  | Pipe Installation | 30d | 2019-05-18 | 2019-06-17 | A54262 | 125.25d | 0d | FF pipe [206 Limt]; FIRE FIGHTING [361 h] | 34.04 | 1625 | MEP | CON | 4 | MB |
|  | 1.4.1.4.1.1.4.1.4.-1 | **2nd Fix** |  | 2019-06-18 | 2019-07-15 |  |  |  |  |  |  |  |  |  |  |
| A54242 |  | Valve and Accessories Installation | 20d | 2019-06-18 | 2019-07-06 | A54232, A54262 | 125.25d | 0d | Fire Fighting Crew [200 h] | 18.86 | 1627 | MEP | CON | 4 | MB |
| A54252 |  | Leak Test | 10d | 2019-07-07 | 2019-07-15 | A54242 | 125.25d | 29d | Fire Fighting Crew [100 h] | 9.43 | 1631 | MEP | CON | 4 | MB |
|  | 1.4.1.4.1.1.4.1.4.-2 | **FF_Final Fix** |  | 2019-08-22 | 2019-09-15 |  |  |  |  |  |  |  |  |  |  |
| A54272 |  | Installation of Sprinklers | 15d | 2019-08-22 | 2019-09-05 | A54232, A54242, A54252, 1F5-FNS-B03-230 | 113.25d | 0d | Fire Fighting Crew [150 h] | 14.15 | 1633 | MEP | CON | 4 | MB |
| A54282 |  | Instalaltion of Fire Extinguisher | 10d | 2019-09-05 | 2019-09-15 | A54232, A54272, A54612 FF, LOE-SUM3-290 FF | 168.25d | 168.75d | Fire Fighting Crew [100 h] | 9.43 |  | MEP | CON | 4 | MB |
| A54612 |  | Installation of Fire hose Cabinet | 5d | 2019-09-05 | 2019-09-10 | A54232, A54272 | 173.25d | 5d | Fire Fighting Crew [50 h] | 4.71 |  | MEP |  | 4 | MB |
|  | 2 | **B03 - CONCOURSE ZONE 05** |  | 2019-03-18 | 2019-07-27 |  |  |  |  |  |  |  |  |  |  |
|  | 1.4.1.4.1.1.4.1.1 | **HVAC SYSTEM** |  | 2019-03-18 | 2019-07-17 |  |  |  |  |  |  |  |  |  |  |
|  | 1.4.1.4.1.1.4.1.1.1. | **1st Fix** |  | 2019-03-18 | 2019-04-03 |  |  |  |  |  |  |  |  |  |  |
| A56382 |  | Hanger and support Installation - Duct | 6d | 2019-03-18 | 2019-03-23 | RM160 | 228.25d | 0d | Mechanical Crew [60 h] | 5.66 | 1546 | MEP | CON | 5 | MB |
| A56452 |  | Hanger and support Installation - CHW | 6d | 2019-03-18 | 2019-03-23 | A56382 SS | 228.25d | 0d | Mechanical Crew [60 h] | 5.66 |  | MEP |  | 5 | MB |
| A56362 |  | Duct Installation | 12d | 2019-03-19 | 2019-03-31 | A56382 SS+2d | 237.75d | 0d | Duct Installation [260 Sqmt]; HVAC [780 h] | 73.55 | 1549 | MEP | CON | 5 | MB |
| A56372 |  | Duct Insulation | 8d | 2019-03-23 | 2019-03-30 | A56362 SS+3d | 261.75d | 98.5d | Duct Insulation [263 Sqmt]; HVAC [190 h] | 17.92 | 1552 | MEP | CON | 5 | MB |
| A56472 |  | Chilled Water Piping Installation | 12d | 2019-03-23 | 2019-04-03 | A56452 | 228.25d | 0d | Mechanical Crew [120 h] | 11.32 |  | MEP |  | 5 | MB |
|  | 1.4.1.4.1.1.4.1.1.-1 | **2nd Fix** |  | 2019-03-31 | 2019-04-22 |  |  |  |  |  |  |  |  |  |  |
| A56462 |  | Installation of Duct Accessories (VD, FD, MSD etc....) | 12d | 2019-03-31 | 2019-04-10 | A56362 | 248.75d | 85.5d | Mechanical Crew [120 h] | 11.32 |  | MEP |  | 5 | MB |
| A56562 |  | CRAC Units Installation | 15d | 2019-03-31 | 2019-04-14 | A56362 | 237.75d | 9d | Mechanical Crew [150 h] | 14.15 |  | MEP |  | 5 | MB |
| A56572 |  | FCU Installation | 15d | 2019-03-31 | 2019-04-14 | A56362 | 237.75d | 9d | Mechanical Crew [150 h] | 14.15 |  | MEP |  | 5 | MB |
| A56582 |  | VRF DX Units Installation | 12d | 2019-03-31 | 2019-04-10 | A56362 | 240.75d | 12d | Mechanical Crew [120 h] | 11.32 |  | MEP |  | 5 | MB |
| A56592 |  | Installation of Attenuators | 10d | 2019-03-31 | 2019-04-09 | A56362 | 242.75d | 14d | Mechanical Crew [100 h] | 9.43 |  | MEP |  | 5 | MB |
| A56602 |  | Installation of HVAC Fans | 10d | 2019-03-31 | 2019-04-09 | A56362 | 242.75d | 14d | Mechanical Crew [100 h] | 9.43 |  | MEP |  | 5 | MB |
| A56622 |  | Pressurization Unit | 8d | 2019-03-31 | 2019-04-07 | A56362 | 244.75d | 16d | Mechanical Crew [80 h] | 7.54 |  | MEP |  | 5 | MB |
| A56632 |  | Dosing pot | 5d | 2019-03-31 | 2019-04-04 | A56362 | 247.75d | 19d | Mechanical Crew [50 h] | 4.71 |  | MEP |  | 5 | MB |
| A56652 |  | Air Handling Units Installation | 12d | 2019-03-31 | 2019-04-10 | A56362 | 240.75d | 12d | Mechanical Crew [120 h] | 11.32 |  | MEP |  | 5 | MB |
| A56492 |  | Valves and Accessories | 10d | 2019-04-03 | 2019-04-13 | A56472 | 228.25d | 0d | Mechanical Crew [100 h] | 9.43 |  | MEP |  | 5 | MB |
| A56612 |  | Air-Cooled Chillers | 15d | 2019-04-03 | 2019-04-17 | A56472 | 233.75d | 5d | Mechanical Crew [150 h] | 14.15 |  | MEP |  | 5 | MB |
| A56662 |  | Chilled Water Pump Installation | 12d | 2019-04-03 | 2019-04-14 | A56472 | 236.75d | 8d | Mechanical Crew [120 h] | 11.32 |  | MEP |  | 5 | MB |
| A56502 |  | Chilled Water Pipe Insulation and Cladding | 10d | 2019-04-13 | 2019-04-22 | A56472, A56492 | 228.25d | 0d | Mechanical Crew [100 h] | 9.43 |  | MEP |  | 5 | MB |

| ID | WBS | Activity | Duration | Start | Finish | Predecessors | Total float | Free float | Resources | Cost | Discipline | AREA | LOCATION | MSP Activity ID | MEP-Phase |
| --- | --- | --- | --- | --- | --- | --- | --- | --- | --- | --- | --- | --- | --- | --- | --- |
|  | 1.4.1.4.1.1.4.1.1.-2 | **HVAC_Final Fix** |  | 2019-04-22 | 2019-07-17 |  |  |  |  |  |  |  |  |  |  |
| A56642 |  | Equuipment Connection | 8d | 2019-04-22 | 2019-04-29 | A56662, A56652, A56612, A56602, A56592, A56562, A56572, A56582, A56632, A56622, A56502 | 228.75d | 65.5d | Mechanical Crew [80 h] | 7.54 | MEP | 5 | MB |  |  |
| A56482 |  | Air Outlets (Grills, Diffusers, Registers etc...) | 15d | 2019-07-03 | 2019-07-17 | A56462, A56362, A56372, A56642, 1F5-FNS-B03-100 | 163.25d | 153.75d | Mechanical Crew [150 h] | 14.15 | MEP | 5 | MB |  |  |
|  | 1.4.1.4.1.1.4.1.2 | **PLUMBING SYSTEM** |  | 2019-03-18 | 2019-07-11 |  |  |  |  |  |  |  |  |  |  |
|  | 1.4.1.4.1.1.4.1.2.1. | **1st Fix** |  | 2019-03-18 | 2019-04-10 |  |  |  |  |  |  |  |  |  |  |
| A56242 |  | Hanger and support Installation | 10d | 2019-03-18 | 2019-03-26 | RM160 | 224.25d | 0d | Plumbing Crew [100 h] | 9.43 | MEP | 5 | MB | 1566 | CON |
| A56282 |  | Drainage and Vent Pipe & Fittings | 20d | 2019-03-23 | 2019-04-09 | A56242 SS+5d | 257.75d | 1d | Plumbing Crew [200 h] | 18.86 | MEP | 5 | MB | 1573 | CON |
| A56252 |  | Domestic Water Pipe & Fittings | 20d | 2019-03-23 | 2019-04-10 | A56242 SS+6d | 224.25d | 0d | Plumbing Crew [200 h] | 18.86 | MEP | 5 | MB | 1570 | CON |
|  | 1.4.1.4.1.1.4.1.2.-1 | **2nd Fix** |  | 2019-04-10 | 2019-04-25 |  |  |  |  |  |  |  |  |  |  |
| A56262 |  | Domestic Water Valves | 12d | 2019-04-10 | 2019-04-22 | A56252 | 224.25d | 0d | Plumbing Crew [120 h] | 11.32 | MEP | 5 | MB | 1571 | CON |
| A56522 |  | Sewege Pumps Installation | 5d | 2019-04-10 | 2019-04-15 | A56282, A56252 | 256.75d | 88d | Plumbing Crew [50 h] | 4.71 | MEP | 5 | MB |  |  |
| A56272 |  | Leak Test | 4d | 2019-04-22 | 2019-04-25 | A56262 | 224.25d | 62d | Plumbing Crew [40 h] | 3.77 | MEP | 5 | MB | 1572 | CON |
|  | 1.4.1.4.1.1.4.1.2.-2 | **PLM_Final Fix** |  | 2019-07-10 | 2019-07-11 |  |  |  |  |  |  |  |  |  |  |
| A56512 |  | Water Heaters | 2d | 2019-07-10 | 2019-07-11 | A56272, A56282, A56252, 1F5-FNS-B03-110 | 168.75d | 0d | Plumbing Crew [20 h] | 1.89 | MEP | 5 | MB |  |  |
| A56532 |  | Floor Drain | 2d | 2019-07-10 | 2019-07-11 | A56512 SS | 168.75d | 0d | Plumbing Crew [20 h] | 1.89 | MEP | 5 | MB |  |  |
| A56542 |  | Wash Basin / Water Closet | 2d | 2019-07-10 | 2019-07-11 | A56532 SS | 168.75d | 0d | Plumbing Crew [20 h] | 1.89 | MEP | 5 | MB |  |  |
| A56552 |  | Eye Wash | 2d | 2019-07-10 | 2019-07-11 | A56542 SS, A56522 | 168.75d | 146.25d | Plumbing Crew [20 h] | 1.89 | MEP | 5 | MB |  |  |
|  | 1.4.1.4.1.1.4.1.3 | **ELECTRICAL / CONTROLS** |  | 2019-03-18 | 2019-07-17 |  |  |  |  |  |  |  |  |  |  |
|  | 1.4.1.4.1.1.4.1.3.1. | **1st Fix** |  | 2019-03-18 | 2019-04-16 |  |  |  |  |  |  |  |  |  |  |
| A56342 |  | Installation of Conduits and Boxes | 12d | 2019-03-18 | 2019-03-28 | RM160 | 97d | 0d | Electrical Crew [120 h] | 11.32 | MEP | 5 | MB | 1592 | CON |
| A56352 |  | Installation of Cable Tray, Ladder and Trunk | 20d | 2019-03-28 | 2019-04-16 | A56342 | 221.75d | 0d | Electrical Crew [200 h] | 18.86 | MEP | 5 | MB | 1593 | CON |
|  | 1.4.1.4.1.1.4.1.3.-1 | **2nd Fix** |  | 2019-03-28 | 2019-06-26 |  |  |  |  |  |  |  |  |  |  |
| A56312 |  | Grounding and Bonding Installation | 20d | 2019-03-28 | 2019-04-16 | A56342 | 97d | 0d | Electrical Crew [200 h] | 18.86 | MEP | 5 | MB | 1596 | CON |
| A56672 |  | Wire Pulling | 20d | 2019-04-16 | 2019-05-05 | A56312 | 97d | 0d | Electrical Crew [200 h] | 18.86 | MEP | 5 | MB |  |  |
| A56732 |  | Installation of Bus Duct System | 20d | 2019-04-16 | 2019-05-05 | A56352 | 221.75d | 59.5d | Electrical Crew [200 h] | 18.86 | MEP | 5 | MB |  |  |
| A56292 |  | Power Cable Laying | 25d | 2019-05-05 | 2019-05-28 | A56672, A56312 | 97d | 0d | Electrical Crew [250 h] | 23.58 | MEP | 5 | MB | 1600 | CON |
| A56302 |  | Continuity Test - Power Cables | 4d | 2019-05-28 | 2019-06-01 | A56292 | 192.75d | 30.5d | Electrical Crew [40 h] | 3.77 | MEP | 5 | MB | 1601 | CON |
| A56682 |  | Installation of Central Battery Equipment | 6d | 2019-05-28 | 2019-06-03 | A56292, A56672 | 190.75d | 28.5d | Electrical Crew [60 h] | 5.66 | MEP | 5 | MB |  |  |
| A56692 |  | Installation of Disconnect Switch | 8d | 2019-05-28 | 2019-06-08 | A56292, A56672 | 188.75d | 26.5d | Electrical Crew [80 h] | 7.54 | MEP | 5 | MB |  |  |
| A56712 |  | Installation of Switch Boards (MDB, EMDB) | 15d | 2019-05-28 | 2019-06-15 | A56292, A56672 | 97d | 0d | Electrical Crew [150 h] | 14.15 | MEP | 5 | MB |  |  |
| A56722 |  | Installation of Panel Boards | 15d | 2019-05-28 | 2019-06-15 | A56292, A56672 | 97d | 0d | Electrical Crew [150 h] | 14.15 | MEP | 5 | MB |  |  |
| A56742 |  | Installation of MCC | 15d | 2019-05-28 | 2019-06-15 | A56292, A56672 | 97d | 0d | Electrical Crew [150 h] | 14.15 | MEP | 5 | MB |  |  |
| A56752 |  | Installation of Lighting Control System | 12d | 2019-05-28 | 2019-06-12 | A56292, A56672 | 100d | 3d | Electrical Crew [120 h] | 11.32 | MEP | 5 | MB |  |  |
| A56702 |  | Installation of Wiring Devices and Outlets | 12d | 2019-06-15 | 2019-06-26 | A56672, A56742, A56722, A56712, A56752 | 97d | 0d | Electrical Crew [120 h] | 11.32 | MEP | 5 | MB |  |  |

| ID | WBS | Activity | Type | Duration | Start | Finish | Predecessors | Total float | Free float | Calendar | Resources | Cost | Discipline | AREA | LOCATION | MSP Activity ID | MEP-Phase |
| --- | --- | --- | --- | --- | --- | --- | --- | --- | --- | --- | --- | --- | --- | --- | --- | --- | --- |
|  | 1.4.1.4.1.1.4.1.3.-2 | **Elec._Final Fix** |  |  | 2019-06-15 | 2019-07-17 |  |  |  |  |  |  |  |  |  |  |  |
| A56762 |  | Panel Board Termination |  | 8d | 2019-06-15 | 2019-06-22 | A56712, A56722, A56742 | 179.75d | 17.5d |  | Electrical Crew [80 h] | 7.54 | MEP | 5 | MB |  |  |
| A56332 |  | Wiring devices Termination |  | 6d | 2019-07-03 | 2019-07-08 | A56682, A56692, A56732, A56752, A56702, A56302, 1F5-FNS-B03-100 | 162.25d | 0d |  | Electrical Crew [60 h] | 5.66 | MEP | 5 | MB | 1617 | CON |
| A56322 |  | Lighting Fixtures Installation and Termination |  | 10d | 2019-07-09 | 2019-07-17 | A56292, A56672, A56762, A56332 | 162.25d | 147.75d |  | Electrical Crew [100 h] | 9.43 | MEP | 5 | MB | 1616 | CON |
|  | 1.4.1.4.1.1.4.1.4 | **FIRE FIGHTING SYSTEM** |  |  | 2019-03-18 | 2019-07-27 |  |  |  |  |  |  |  |  |  |  |  |
|  | 1.4.1.4.1.1.4.1.4.1. | **1st Fix** |  |  | 2019-03-18 | 2019-04-28 |  |  |  |  |  |  |  |  |  |  |  |
| A56422 |  | Fire Fighting Hangers & Supports |  | 15d | 2019-03-18 | 2019-03-31 | RM160 | 191.25d | 0d |  | Fire Fighting Crew [150 h] | 14.15 | MEP | 5 | MB | 1622 | CON |
| A56392 |  | Pipe Installation |  | 30d | 2019-04-01 | 2019-04-28 | A56422 | 191.25d | 0d |  | FIRE FIGHTING [361 h]; FF pipe [206 Limt] | 34.04 | MEP | 5 | MB | 1625 | CON |
|  | 1.4.1.4.1.1.4.1.4.-1 | **2nd Fix** |  |  | 2019-04-29 | 2019-05-26 |  |  |  |  |  |  |  |  |  |  |  |
| A56402 |  | Valve and Accessories Installation |  | 20d | 2019-04-29 | 2019-05-16 | A56392, A56422 | 191.25d | 0d |  | Fire Fighting Crew [200 h] | 18.86 | MEP | 5 | MB | 1627 | CON |
| A56412 |  | Leak Test |  | 10d | 2019-05-18 | 2019-05-26 | A56402 | 191.25d | 29d |  | Fire Fighting Crew [100 h] | 9.43 | MEP | 5 | MB | 1631 | CON |
|  | 1.4.1.4.1.1.4.1.4.-2 | **FF_Final Fix** |  |  | 2019-07-03 | 2019-07-27 |  |  |  |  |  |  |  |  |  |  |  |
| A56432 |  | Installation of Sprinklers |  | 15d | 2019-07-03 | 2019-07-17 | A56392, A56402, A56412, 1F5-FNS-B03-100 | 163.25d | 0d |  | Fire Fighting Crew [150 h] | 14.15 | MEP | 5 | MB | 1633 | CON |
| A56442 |  | Instalaltion of Fire Extinguisher |  | 10d | 2019-07-17 | 2019-07-27 | A56392, A56432, A56772 FF | 218.25d | 218.75d |  | Fire Fighting Crew [100 h] | 9.43 | MEP | 5 | MB |  | CON |
| A56772 |  | Installation of Fire hose Cabinet |  | 5d | 2019-07-17 | 2019-07-22 | A56392, A56432 | 223.25d | 5d |  | Fire Fighting Crew [50 h] | 4.71 | MEP | 5 | MB |  |  |
|  | 6 | **CENTRAL CONCOURSE - ZONE 03** |  |  | 2019-06-16 | 2019-10-26 |  |  |  |  |  |  |  |  |  |  |  |
| LOE-SUM3-300 |  | Central . B03 - MEP Works; 1st & 2nd Fix | level of effort | 109.12d | 2019-06-16 | 2019-09-25 | RM170 | 70.38d | 0d | Saudi |  |  | MEP |  |  |  |  |
| LOE-SUM3-310 |  | Central . B03 - MEP Works; Final fix | level of effort | 103.75d | 2019-07-21 | 2019-10-26 | LOE-SUM3-300, A58802 SS | 125.75d | 0d | Saudi |  |  | MEP |  |  |  |  |
|  | 3 | **B03 - CONCOURSEZONE 03** |  |  | 2019-06-16 | 2019-10-26 |  |  |  |  |  |  |  |  |  |  |  |
|  | 1.4.1.4.1.1.4.1.1 | **HVAC SYSTEM** |  |  | 2019-06-16 | 2019-10-16 |  |  |  |  |  |  |  |  |  |  |  |
|  | 1.4.1.4.1.1.4.1.1.1. | **1st Fix** |  |  | 2019-06-16 | 2019-07-02 |  |  |  |  |  |  |  |  |  |  |  |
| A58542 |  | Hanger and support Installation - Duct |  | 6d | 2019-06-16 | 2019-06-20 | RM170 | 127.25d | 0d |  | Mechanical Crew [60 h] | 5.66 | MEP | 3 | MB | 1546 | CON |
| A58612 |  | Hanger and support Installation - CHW |  | 6d | 2019-06-16 | 2019-06-20 | A58542 SS | 127.25d | 0d |  | Mechanical Crew [60 h] | 5.66 | MEP | 3 | MB |  |  |
| A58522 |  | Duct Installation |  | 12d | 2019-06-17 | 2019-06-29 | A58542 SS+2d | 145.25d | 0d |  | Duct Installation [520 Sqmt]; HVAC [1560 h] | 147.11 | MEP | 3 | MB | 1549 | CON |
| A58532 |  | Duct Insulation |  | 8d | 2019-06-20 | 2019-06-27 | A58522 SS+3d | 169.25d | 98.5d |  | Duct Insulation [180 Sqmt]; HVAC [128 h] | 12.07 | MEP | 3 | MB | 1552 | CON |
| A58632 |  | Chilled Water Piping Installation |  | 12d | 2019-06-20 | 2019-07-02 | A58612 | 127.25d | 0d |  | Mechanical Crew [120 h] | 11.32 | MEP | 3 | MB |  |  |

| ID | WBS | Activity | Duration | Start | Finish | Predecessors | Total float | Free float | Resources | Cost | Discipline | AREA | LOCATION | MSP Activity ID | MEP-Phase |
| --- | --- | --- | --- | --- | --- | --- | --- | --- | --- | --- | --- | --- | --- | --- | --- |
|  | 1.4.1.4.1.1.4.1.1.-1 | **2nd Fix** |  | 2019-06-29 | 2019-07-21 |  |  |  |  |  |  |  |  |  |  |
| A58622 |  | Installation of Duct Accessories (VD, FD, MSD etc....) | 12d | 2019-06-29 | 2019-07-09 | A58522 | 156.25d | 85.5d | Mechanical Crew [120 h] | 11.32 | MEP | 3 | MB |  |  |
| A58722 |  | CRAC Units Installation | 15d | 2019-06-29 | 2019-07-13 | A58522 | 145.25d | 9d | Mechanical Crew [150 h] | 14.15 | MEP | 3 | MB |  |  |
| A58732 |  | FCU Installation | 15d | 2019-06-29 | 2019-07-13 | A58522 | 145.25d | 9d | Mechanical Crew [150 h] | 14.15 | MEP | 3 | MB |  |  |
| A58742 |  | VRF DX Units Installation | 12d | 2019-06-29 | 2019-07-09 | A58522 | 148.25d | 12d | Mechanical Crew [120 h] | 11.32 | MEP | 3 | MB |  |  |
| A58752 |  | Installation of Attenuators | 10d | 2019-06-29 | 2019-07-08 | A58522 | 150.25d | 14d | Mechanical Crew [100 h] | 9.43 | MEP | 3 | MB |  |  |
| A58762 |  | Installation of HVAC Fans | 10d | 2019-06-29 | 2019-07-08 | A58522 | 150.25d | 14d | Mechanical Crew [100 h] | 9.43 | MEP | 3 | MB |  |  |
| A58782 |  | Pressurization Unit | 8d | 2019-06-29 | 2019-07-06 | A58522 | 152.25d | 16d | Mechanical Crew [80 h] | 7.54 | MEP | 3 | MB |  |  |
| A58792 |  | Dosing pot | 5d | 2019-06-29 | 2019-07-03 | A58522 | 155.25d | 19d | Mechanical Crew [50 h] | 4.71 | MEP | 3 | MB |  |  |
| A58812 |  | Air Handling Units Installation | 12d | 2019-06-29 | 2019-07-09 | A58522 | 148.25d | 12d | Mechanical Crew [120 h] | 11.32 | MEP | 3 | MB |  |  |
| A58652 |  | Valves and Accessories | 10d | 2019-07-02 | 2019-07-11 | A58632 | 127.25d | 0d | Mechanical Crew [100 h] | 9.43 | MEP | 3 | MB |  |  |
| A58772 |  | Air-Cooled Chillers | 15d | 2019-07-02 | 2019-07-16 | A58632 | 141.25d | 5d | Mechanical Crew [150 h] | 14.15 | MEP | 3 | MB |  |  |
| A58822 |  | Chilled Water Pump Installation | 12d | 2019-07-02 | 2019-07-13 | A58632 | 144.25d | 8d | Mechanical Crew [120 h] | 11.32 | MEP | 3 | MB |  |  |
| A58662 |  | Chilled Water Pipe Insulation and Cladding | 10d | 2019-07-11 | 2019-07-21 | A58632, A58652 | 127.25d | 0d | Mechanical Crew [100 h] | 9.43 | MEP | 3 | MB |  |  |
|  | 1.4.1.4.1.1.4.1.1.-2 | **HVAC_Final Fix** |  | 2019-07-21 | 2019-10-16 |  |  |  |  |  |  |  |  |  |  |
| A58802 |  | Equuipment Connection | 8d | 2019-07-21 | 2019-07-28 | A58822, A58812, A58772, A58762, A58752, A58722, A58732, A58742, A58792, A58782, A58662 | 136.25d | 65.5d | Mechanical Crew [80 h] | 7.54 | MEP | 3 | MB |  |  |
| A58642 |  | Air Outlets (Grills, Diffusers, Registers etc...) | 15d | 2019-10-02 | 2019-10-16 | A58622, A58522, A58532, A58802, 1F5-FNS-B03-360 | 70.75d | 61.25d | Mechanical Crew [150 h] | 14.15 | MEP | 3 | MB |  |  |
|  | 1.4.1.4.1.1.4.1.2 | **PLUMBING SYSTEM** |  | 2019-06-16 | 2019-07-27 |  |  |  |  |  |  |  |  |  |  |
|  | 1.4.1.4.1.1.4.1.2.1. | **1st Fix** |  | 2019-06-16 | 2019-07-09 |  |  |  |  |  |  |  |  |  |  |
| A58402 |  | Hanger and support Installation | 10d | 2019-06-16 | 2019-06-24 | RM170 | 123.25d | 0d | Plumbing Crew [100 h] | 9.43 | MEP | 3 | MB | 1566 | CON |
| A58442 |  | Drainage and Vent Pipe & Fittings | 20d | 2019-06-20 | 2019-07-08 | A58402 SS+5d | 165.25d | 1d | Plumbing Crew [200 h] | 18.86 | MEP | 3 | MB | 1573 | CON |
| A58412 |  | Domestic Water Pipe & Fittings | 20d | 2019-06-20 | 2019-07-09 | A58402 SS+6d | 123.25d | 0d | Plumbing Crew [200 h] | 18.86 | MEP | 3 | MB | 1570 | CON |
|  | 1.4.1.4.1.1.4.1.2.-1 | **2nd Fix** |  | 2019-07-09 | 2019-07-24 |  |  |  |  |  |  |  |  |  |  |
| A58422 |  | Domestic Water Valves | 12d | 2019-07-09 | 2019-07-21 | A58412 | 123.25d | 0d | Plumbing Crew [120 h] | 11.32 | MEP | 3 | MB | 1571 | CON |
| A58682 |  | Sewege Pumps Installation | 5d | 2019-07-09 | 2019-07-14 | A58442, A58412 | 164.25d | 11d | Plumbing Crew [50 h] | 4.71 | MEP | 3 | MB |  |  |
| A58432 |  | Leak Test | 4d | 2019-07-21 | 2019-07-24 | A58422 | 123.25d | 0d | Plumbing Crew [40 h] | 3.77 | MEP | 3 | MB | 1572 | CON |

| ID | WBS | Activity | Duration | Start | Finish | Predecessors | Total float | Free float | Resources | Cost | Discipline | AREA | LOCATION | MSP Activity ID | MEP-Phase |
| --- | --- | --- | --- | --- | --- | --- | --- | --- | --- | --- | --- | --- | --- | --- | --- |
|  | 1.4.1.4.1.1.4.1.2.-2 | **PLM_Final Fix** |  | 2019-07-24 | 2019-07-27 |  |  |  |  |  |  |  |  |  |  |
| A58672 |  | Water Heaters | 2d | 2019-07-24 | 2019-07-27 | A58432, A58442, A58412, 1F5-FNS-B03-320 | 153.25d | 0d | Plumbing Crew [20 h] | 1.89 | MEP | 3 | MB |  |  |
| A58692 |  | Floor Drain | 2d | 2019-07-24 | 2019-07-27 | A58672 SS | 153.25d | 0d | Plumbing Crew [20 h] | 1.89 | MEP | 3 | MB |  |  |
| A58702 |  | Wash Basin / Water Closet | 2d | 2019-07-24 | 2019-07-27 | A58692 SS | 153.25d | 0d | Plumbing Crew [20 h] | 1.89 | MEP | 3 | MB |  |  |
| A58712 |  | Eye Wash | 2d | 2019-07-24 | 2019-07-27 | A58702 SS, A58682 | 153.25d | 130.75d | Plumbing Crew [20 h] | 1.89 | MEP | 3 | MB |  |  |
|  | 1.4.1.4.1.1.4.1.3 | **ELECTRICAL / CONTROLS** |  | 2019-06-16 | 2019-10-17 |  |  |  |  |  |  |  |  |  |  |
|  | 1.4.1.4.1.1.4.1.3.1. | **1st Fix** |  | 2019-06-16 | 2019-07-15 |  |  |  |  |  |  |  |  |  |  |
| A58502 |  | Installation of Conduits and Boxes | 12d | 2019-06-16 | 2019-06-26 | RM170 | 61.25d | 0d | Electrical Crew [120 h] | 11.32 | MEP | 3 | MB | 1592 | CON |
| A58512 |  | Installation of Cable Tray, Ladder and Trunk | 20d | 2019-06-26 | 2019-07-15 | A58502 | 129.25d | 0d | Electrical Crew [200 h] | 18.86 | MEP | 3 | MB | 1593 | CON |
|  | 1.4.1.4.1.1.4.1.3.-1 | **2nd Fix** |  | 2019-06-26 | 2019-09-25 |  |  |  |  |  |  |  |  |  |  |
| A58472 |  | Grounding and Bonding Installation | 20d | 2019-06-26 | 2019-07-15 | A58502 | 61.25d | 0d | Electrical Crew [200 h] | 18.86 | MEP | 3 | MB | 1596 | CON |
| A58832 |  | Wire Pulling | 20d | 2019-07-15 | 2019-08-03 | A58472 | 61.25d | 0d | Electrical Crew [200 h] | 18.86 | MEP | 3 | MB |  |  |
| A58892 |  | Installation of Bus Duct System | 20d | 2019-07-15 | 2019-08-03 | A58512 | 129.25d | 59.5d | Electrical Crew [200 h] | 18.86 | MEP | 3 | MB |  |  |
| A58452 |  | Power Cable Laying | 25d | 2019-08-03 | 2019-08-29 | A58832, A58472 | 61.25d | 0d | Electrical Crew [250 h] | 23.58 | MEP | 3 | MB | 1600 | CON |
| A58462 |  | Continuity Test - Power Cables | 4d | 2019-08-29 | 2019-09-02 | A58452 | 100.25d | 30.5d | Electrical Crew [40 h] | 3.77 | MEP | 3 | MB | 1601 | CON |
| A58842 |  | Installation of Central Battery Equipment | 6d | 2019-08-29 | 2019-09-04 | A58452, A58832 | 98.25d | 28.5d | Electrical Crew [60 h] | 5.66 | MEP | 3 | MB |  |  |
| A58852 |  | Installation of Disconnect Switch | 8d | 2019-08-29 | 2019-09-05 | A58452, A58832 | 96.25d | 26.5d | Electrical Crew [80 h] | 7.54 | MEP | 3 | MB |  |  |
| A58872 |  | Installation of Switch Boards (MDB, EMDB) | 15d | 2019-08-29 | 2019-09-12 | A58452, A58832 | 61.25d | 0d | Electrical Crew [150 h] | 14.15 | MEP | 3 | MB |  |  |
| A58882 |  | Installation of Panel Boards | 15d | 2019-08-29 | 2019-09-12 | A58452, A58832 | 61.25d | 0d | Electrical Crew [150 h] | 14.15 | MEP | 3 | MB |  |  |
| A58902 |  | Installation of MCC | 15d | 2019-08-29 | 2019-09-12 | A58452, A58832 | 61.25d | 0d | Electrical Crew [150 h] | 14.15 | MEP | 3 | MB |  |  |
| A58912 |  | Installation of Lighting Control System | 12d | 2019-08-29 | 2019-09-10 | A58452, A58832 | 64.25d | 3d | Electrical Crew [120 h] | 11.32 | MEP | 3 | MB |  |  |
| A58862 |  | Installation of Wiring Devices and Outlets | 12d | 2019-09-12 | 2019-09-25 | A58832, A58902, A58882, A58872, A58912 | 61.25d | 0d | Electrical Crew [120 h] | 11.32 | MEP | 3 | MB |  |  |
|  | 1.4.1.4.1.1.4.1.3.-2 | **Elec._Final Fix** |  | 2019-09-12 | 2019-10-17 |  |  |  |  |  |  |  |  |  |  |
| A58922 |  | Panel Board Termination | 8d | 2019-09-12 | 2019-09-19 | A58872, A58882, A58902 | 87.25d | 17.5d | Electrical Crew [80 h] | 7.54 | MEP | 3 | MB |  |  |
| A58492 |  | Wiring devices Termination | 6d | 2019-10-02 | 2019-10-08 | A58842, A58852, A58892, A58912, A58862, A58462, 1F5-FNS-B03-360 | 69.75d | 0d | Electrical Crew [60 h] | 5.66 | MEP | 3 | MB | 1617 | CON |
| A58482 |  | Lighting Fixtures Installation and Termination | 10d | 2019-10-08 | 2019-10-17 | A58452, A58832, A58922, A58492, LOE-SUM3-310 FF | 69.75d | 55.25d | Electrical Crew [100 h] | 9.43 | MEP | 3 | MB | 1616 | CON |

| ID | WBS | Activity | Type | Duration | Start | Finish | Predecessors | Total float | Free float | Calendar | Resources | Cost | MSP Activity ID | Discipline | MEP-Phase | AREA | LOCATION |
| --- | --- | --- | --- | --- | --- | --- | --- | --- | --- | --- | --- | --- | --- | --- | --- | --- | --- |
|  | 1.4.1.4.1.1.4.1.4 | **FIRE FIGHTING SYSTEM** |  |  | 2019-06-16 | 2019-10-26 |  |  |  |  |  |  |  |  |  |  |  |
|  | 1.4.1.4.1.1.4.1.4.1. | **1st Fix** |  |  | 2019-06-16 | 2019-07-27 |  |  |  |  |  |  |  |  |  |  |  |
| A58582 |  | Fire Fighting Hangers & Supports |  | 15d | 2019-06-16 | 2019-06-29 | RM170 | 90.25d | 0d |  | Fire Fighting Crew [150 h] | 14.15 | 1622 | MEP | CON | 3 | MB |
| A58552 |  | Pipe Installation |  | 30d | 2019-06-30 | 2019-07-27 | A58582 | 90.25d | 0d |  | FF pipe [412 Limt]; FIRE FIGHTING [721 h] | 67.99 | 1625 | MEP | CON | 3 | MB |
|  | 1.4.1.4.1.1.4.1.4.-1 | **2nd Fix** |  |  | 2019-07-28 | 2019-08-27 |  |  |  |  |  |  |  |  |  |  |  |
| A58562 |  | Valve and Accessories Installation |  | 20d | 2019-07-28 | 2019-08-18 | A58552, A58582 | 90.25d | 0d |  | Fire Fighting Crew [200 h] | 18.86 | 1627 | MEP | CON | 3 | MB |
| A58572 |  | Leak Test |  | 10d | 2019-08-19 | 2019-08-27 | A58562 | 90.25d | 29d |  | Fire Fighting Crew [100 h] | 9.43 | 1631 | MEP | CON | 3 | MB |
|  | 1.4.1.4.1.1.4.1.4.-2 | **FF_Final Fix** |  |  | 2019-10-02 | 2019-10-26 |  |  |  |  |  |  |  |  |  |  |  |
| A58592 |  | Installation of Sprinklers |  | 15d | 2019-10-02 | 2019-10-16 | A58552, A58562, A58572, 1F5-FNS-B03-360 | 70.75d | 0d |  | Fire Fighting Crew [150 h] | 14.15 | 1633 | MEP | CON | 3 | MB |
| A58602 |  | Instalaltion of Fire Extinguisher |  | 10d | 2019-10-16 | 2019-10-26 | A58552, A58592, A58932 FF, LOE-SUM3-310 FF | 125.75d | 126.25d |  | Fire Fighting Crew [100 h] | 9.43 |  | MEP | CON | 3 | MB |
| A58932 |  | Installation of Fire hose Cabinet |  | 5d | 2019-10-16 | 2019-10-21 | A58552, A58592 | 130.75d | 5d |  | Fire Fighting Crew [50 h] | 4.71 |  | MEP |  | 3 | MB |
|  | 1 | **NORTH CONCOURSE - 01 AND 02** |  |  | 2019-06-30 | 2019-11-27 |  |  |  |  |  |  |  |  |  |  |  |
| LOE-SUM3-320 |  | North . B03 - MEP Works; 1st & 2nd Fix | level of effort | 124.25d | 2019-06-30 | 2019-10-23 | RM180 | 40.25d | 0d | Saudi |  |  |  | MEP |  |  |  |
| LOE-SUM3-330 |  | North . B03 - MEP Works; Final fix | level of effort | 123.75d | 2019-08-04 | 2019-11-27 | LOE-SUM3-320, A63122 SS | 90.75d | 0d | Saudi |  |  |  | MEP |  |  |  |
|  | 4 | **B03 - CONCOURSE ZONE 01** |  |  | 2019-07-14 | 2019-11-27 |  |  |  |  |  |  |  |  |  |  |  |
|  | 1.4.1.4.1.1.4.1.1 | **HVAC SYSTEM** |  |  | 2019-07-14 | 2019-11-13 |  |  |  |  |  |  |  |  |  |  |  |
|  | 1.4.1.4.1.1.4.1.1.1. | **1st Fix** |  |  | 2019-07-14 | 2019-07-30 |  |  |  |  |  |  |  |  |  |  |  |
| A60702 |  | Hanger and support Installation - Duct |  | 6d | 2019-07-14 | 2019-07-18 | RM190 | 105.75d | 0d |  | Mechanical Crew [60 h] | 5.66 | 1546 | MEP | CON | 1 | MB |
| A60772 |  | Hanger and support Installation - CHW |  | 6d | 2019-07-14 | 2019-07-18 | A60702 SS | 105.75d | 0d |  | Mechanical Crew [60 h] | 5.66 |  | MEP |  | 1 | MB |
| A60682 |  | Duct Installation |  | 12d | 2019-07-15 | 2019-07-27 | A60702 SS+2d | 115.25d | 0d |  | Duct Installation [260 Sqmt]; HVAC [780 h] | 73.55 | 1549 | MEP | CON | 1 | MB |
| A60692 |  | Duct Insulation |  | 8d | 2019-07-18 | 2019-07-25 | A60682 SS+3d | 139.25d | 98.5d |  | Duct Insulation [180 Sqmt]; HVAC [128 h] | 12.07 | 1552 | MEP | CON | 1 | MB |
| A60792 |  | Chilled Water Piping Installation |  | 12d | 2019-07-18 | 2019-07-30 | A60772 | 105.75d | 0d |  | Mechanical Crew [120 h] | 11.32 |  | MEP |  | 1 | MB |
|  | 1.4.1.4.1.1.4.1.1.-1 | **2nd Fix** |  |  | 2019-07-27 | 2019-08-21 |  |  |  |  |  |  |  |  |  |  |  |
| A60782 |  | Installation of Duct Accessories (VD, FD, MSD etc....) |  | 12d | 2019-07-27 | 2019-08-06 | A60682 | 126.25d | 85.5d |  | Mechanical Crew [120 h] | 11.32 |  | MEP |  | 1 | MB |
| A60882 |  | CRAC Units Installation |  | 15d | 2019-07-27 | 2019-08-13 | A60682 | 115.25d | 9d |  | Mechanical Crew [150 h] | 14.15 |  | MEP |  | 1 | MB |
| A60892 |  | FCU Installation |  | 15d | 2019-07-27 | 2019-08-13 | A60682 | 115.25d | 9d |  | Mechanical Crew [150 h] | 14.15 |  | MEP |  | 1 | MB |
| A60902 |  | VRF DX Units Installation |  | 12d | 2019-07-27 | 2019-08-06 | A60682 | 118.25d | 12d |  | Mechanical Crew [120 h] | 11.32 |  | MEP |  | 1 | MB |
| A60912 |  | Installation of Attenuators |  | 10d | 2019-07-27 | 2019-08-05 | A60682 | 120.25d | 14d |  | Mechanical Crew [100 h] | 9.43 |  | MEP |  | 1 | MB |
| A60922 |  | Installation of HVAC Fans |  | 10d | 2019-07-27 | 2019-08-05 | A60682 | 120.25d | 14d |  | Mechanical Crew [100 h] | 9.43 |  | MEP |  | 1 | MB |
| A60942 |  | Pressurization Unit |  | 8d | 2019-07-27 | 2019-08-03 | A60682 | 122.25d | 16d |  | Mechanical Crew [80 h] | 7.54 |  | MEP |  | 1 | MB |
| A60952 |  | Dosing pot |  | 5d | 2019-07-27 | 2019-07-31 | A60682 | 125.25d | 19d |  | Mechanical Crew [50 h] | 4.71 |  | MEP |  | 1 | MB |
| A60972 |  | Air Handling Units Installation |  | 12d | 2019-07-27 | 2019-08-06 | A60682 | 118.25d | 12d |  | Mechanical Crew [120 h] | 11.32 |  | MEP |  | 1 | MB |
| A60812 |  | Valves and Accessories |  | 10d | 2019-07-30 | 2019-08-08 | A60792 | 105.75d | 0d |  | Mechanical Crew [100 h] | 9.43 |  | MEP |  | 1 | MB |
| A60932 |  | Air-Cooled Chillers |  | 15d | 2019-07-30 | 2019-08-17 | A60792 | 111.25d | 5d |  | Mechanical Crew [150 h] | 14.15 |  | MEP |  | 1 | MB |
| A60982 |  | Chilled Water Pump Installation |  | 12d | 2019-07-30 | 2019-08-13 | A60792 | 114.25d | 8d |  | Mechanical Crew [120 h] | 11.32 |  | MEP |  | 1 | MB |
| A60822 |  | Chilled Water Pipe Insulation and Cladding |  | 10d | 2019-08-08 | 2019-08-21 | A60792, A60812 | 105.75d | 0d |  | Mechanical Crew [100 h] | 9.43 |  | MEP |  | 1 | MB |

| ID | WBS | Activity | Duration | Start | Finish | Predecessors | Total float | Free float | Resources | Cost | Discipline | AREA | LOCATION | MSP Activity ID | MEP-Phase |
| --- | --- | --- | --- | --- | --- | --- | --- | --- | --- | --- | --- | --- | --- | --- | --- |
|  | 1.4.1.4.1.1.4.1.1.-2 | **HVAC_Final Fix** |  | 2019-08-21 | 2019-11-13 |  |  |  |  |  |  |  |  |  |  |
| A60962 |  | Equuipment Connection | 8d | 2019-08-21 | 2019-08-28 | A60982, A60972, A60932, A60922, A60912, A60882, A60892, A60902, A60952, A60942, A60822 | 106.25d | 65.5d | Mechanical Crew [80 h] | 7.54 | MEP | 1 | MB |  |  |
| A60802 |  | Air Outlets (Grills, Diffusers, Registers etc...) | 15d | 2019-10-30 | 2019-11-13 | A60782, A60682, A60692, A60962, 1F5-FNS-B03-620 | 40.75d | 31.25d | Mechanical Crew [150 h] | 14.15 | MEP | 1 | MB |  |  |
|  | 1.4.1.4.1.1.4.1.2 | **PLUMBING SYSTEM** |  | 2019-07-14 | 2019-11-07 |  |  |  |  |  |  |  |  |  |  |
|  | 1.4.1.4.1.1.4.1.2.1. | **1st Fix** |  | 2019-07-14 | 2019-08-06 |  |  |  |  |  |  |  |  |  |  |
| A60562 |  | Hanger and support Installation | 10d | 2019-07-14 | 2019-07-22 | RM190 | 101.75d | 0d | Plumbing Crew [100 h] | 9.43 | MEP | 1 | MB | 1566 | CON |
| A60602 |  | Drainage and Vent Pipe & Fittings | 20d | 2019-07-18 | 2019-08-05 | A60562 SS+5d | 135.25d | 1d | Plumbing Crew [200 h] | 18.86 | MEP | 1 | MB | 1573 | CON |
| A60572 |  | Domestic Water Pipe & Fittings | 20d | 2019-07-18 | 2019-08-06 | A60562 SS+6d | 101.75d | 0d | Plumbing Crew [200 h] | 18.86 | MEP | 1 | MB | 1570 | CON |
|  | 1.4.1.4.1.1.4.1.2.-1 | **2nd Fix** |  | 2019-08-06 | 2019-08-25 |  |  |  |  |  |  |  |  |  |  |
| A60582 |  | Domestic Water Valves | 12d | 2019-08-06 | 2019-08-21 | A60572 | 101.75d | 0d | Plumbing Crew [120 h] | 11.32 | MEP | 1 | MB | 1571 | CON |
| A60842 |  | Sewege Pumps Installation | 5d | 2019-08-06 | 2019-08-14 | A60602, A60572 | 134.25d | 88d | Plumbing Crew [50 h] | 4.71 | MEP | 1 | MB |  |  |
| A60592 |  | Leak Test | 4d | 2019-08-21 | 2019-08-25 | A60582 | 101.75d | 62d | Plumbing Crew [40 h] | 3.77 | MEP | 1 | MB | 1572 | CON |
|  | 1.4.1.4.1.1.4.1.2.-2 | **PLM_Final Fix** |  | 2019-11-06 | 2019-11-07 |  |  |  |  |  |  |  |  |  |  |
| A60832 |  | Water Heaters | 2d | 2019-11-06 | 2019-11-07 | A60592, A60602, A60572, 1F5-FNS-B03-630 | 46.25d | 0d | Plumbing Crew [20 h] | 1.89 | MEP | 1 | MB |  |  |
| A60852 |  | Floor Drain | 2d | 2019-11-06 | 2019-11-07 | A60832 SS | 46.25d | 0d | Plumbing Crew [20 h] | 1.89 | MEP | 1 | MB |  |  |
| A60862 |  | Wash Basin / Water Closet | 2d | 2019-11-06 | 2019-11-07 | A60852 SS | 46.25d | 0d | Plumbing Crew [20 h] | 1.89 | MEP | 1 | MB |  |  |
| A60872 |  | Eye Wash | 2d | 2019-11-06 | 2019-11-07 | A60862 SS, A60842 | 46.25d | 23.75d | Plumbing Crew [20 h] | 1.89 | MEP | 1 | MB |  |  |
|  | 1.4.1.4.1.1.4.1.3 | **ELECTRICAL / CONTROLS** |  | 2019-07-14 | 2019-11-14 |  |  |  |  |  |  |  |  |  |  |
|  | 1.4.1.4.1.1.4.1.3.1. | **1st Fix** |  | 2019-07-14 | 2019-08-15 |  |  |  |  |  |  |  |  |  |  |
| A60662 |  | Installation of Conduits and Boxes | 12d | 2019-07-14 | 2019-07-24 | RM190 | 39.75d | 0d | Electrical Crew [120 h] | 11.32 | MEP | 1 | MB | 1592 | CON |
| A60672 |  | Installation of Cable Tray, Ladder and Trunk | 20d | 2019-07-24 | 2019-08-15 | A60662 | 99.25d | 0d | Electrical Crew [200 h] | 18.86 | MEP | 1 | MB | 1593 | CON |
|  | 1.4.1.4.1.1.4.1.3.-1 | **2nd Fix** |  | 2019-07-24 | 2019-10-23 |  |  |  |  |  |  |  |  |  |  |
| A60632 |  | Grounding and Bonding Installation | 20d | 2019-07-24 | 2019-08-15 | A60662 | 39.75d | 0d | Electrical Crew [200 h] | 18.86 | MEP | 1 | MB | 1596 | CON |
| A60992 |  | Wire Pulling | 20d | 2019-08-15 | 2019-09-03 | A60632 | 39.75d | 0d | Electrical Crew [200 h] | 18.86 | MEP | 1 | MB |  |  |
| A61052 |  | Installation of Bus Duct System | 20d | 2019-08-15 | 2019-09-03 | A60672 | 99.25d | 59.5d | Electrical Crew [200 h] | 18.86 | MEP | 1 | MB |  |  |
| A60612 |  | Power Cable Laying | 25d | 2019-09-03 | 2019-09-28 | A60992, A60632 | 39.75d | 0d | Electrical Crew [250 h] | 23.58 | MEP | 1 | MB | 1600 | CON |
| A60622 |  | Continuity Test - Power Cables | 4d | 2019-09-28 | 2019-10-01 | A60612 | 70.25d | 30.5d | Electrical Crew [40 h] | 3.77 | MEP | 1 | MB | 1601 | CON |
| A61002 |  | Installation of Central Battery Equipment | 6d | 2019-09-28 | 2019-10-03 | A60612, A60992 | 68.25d | 28.5d | Electrical Crew [60 h] | 5.66 | MEP | 1 | MB |  |  |
| A61012 |  | Installation of Disconnect Switch | 8d | 2019-09-28 | 2019-10-06 | A60612, A60992 | 66.25d | 26.5d | Electrical Crew [80 h] | 7.54 | MEP | 1 | MB |  |  |
| A61032 |  | Installation of Switch Boards (MDB, EMDB) | 15d | 2019-09-28 | 2019-10-12 | A60612, A60992 | 39.75d | 0d | Electrical Crew [150 h] | 14.15 | MEP | 1 | MB |  |  |
| A61042 |  | Installation of Panel Boards | 15d | 2019-09-28 | 2019-10-12 | A60612, A60992 | 39.75d | 0d | Electrical Crew [150 h] | 14.15 | MEP | 1 | MB |  |  |
| A61062 |  | Installation of MCC | 15d | 2019-09-28 | 2019-10-12 | A60612, A60992 | 39.75d | 0d | Electrical Crew [150 h] | 14.15 | MEP | 1 | MB |  |  |
| A61072 |  | Installation of Lighting Control System | 12d | 2019-09-28 | 2019-10-09 | A60612, A60992 | 42.75d | 3d | Electrical Crew [120 h] | 11.32 | MEP | 1 | MB |  |  |
| A61022 |  | Installation of Wiring Devices and Outlets | 12d | 2019-10-12 | 2019-10-23 | A60992, A61062, A61042, A61032, A61072 | 39.75d | 0d | Electrical Crew [120 h] | 11.32 | MEP | 1 | MB |  |  |

| ID | WBS | Activity | Duration | Start | Finish | Predecessors | Total float | Free float | Resources | Cost | Discipline | AREA | LOCATION | MSP Activity ID | MEP-Phase |
| --- | --- | --- | --- | --- | --- | --- | --- | --- | --- | --- | --- | --- | --- | --- | --- |
|  | 1.4.1.4.1.1.4.1.3.-2 | **Elec._Final Fix** |  | 2019-10-12 | 2019-11-14 |  |  |  |  |  |  |  |  |  |  |
| A61082 |  | Panel Board Termination | 8d | 2019-10-12 | 2019-10-20 | A61032, A61042, A61062 | 57.25d | 17.5d | Electrical Crew [80 h] | 7.54 | MEP | 1 | MB |  |  |
| A60652 |  | Wiring devices Termination | 6d | 2019-10-30 | 2019-11-05 | A61002, A61012, A61052, A61072, A61022, A60622, 1F5-FNS-B03-620 | 39.75d | 0d | Electrical Crew [60 h] | 5.66 | MEP | 1 | MB | 1617 | CON |
| A60642 |  | Lighting Fixtures Installation and Termination | 10d | 2019-11-05 | 2019-11-14 | A60612, A60992, A60652, A61082 | 39.75d | 25.25d | Electrical Crew [100 h] | 9.43 | MEP | 1 | MB | 1616 | CON |
|  | 1.4.1.4.1.1.4.1.4 | **FIRE FIGHTING SYSTEM** |  | 2019-07-14 | 2019-11-27 |  |  |  |  |  |  |  |  |  |  |
|  | 1.4.1.4.1.1.4.1.4.1. | **1st Fix** |  | 2019-07-14 | 2019-08-27 |  |  |  |  |  |  |  |  |  |  |
| A60742 |  | Fire Fighting Hangers & Supports | 15d | 2019-07-14 | 2019-07-27 | RM190 | 68.75d | 0d | Fire Fighting Crew [150 h] | 14.15 | MEP | 1 | MB | 1622 | CON |
| A60712 |  | Pipe Installation | 30d | 2019-07-28 | 2019-08-27 | A60742 | 68.75d | 0d | FIRE FIGHTING [361 h]; FF pipe [206 Limt] | 34.04 | MEP | 1 | MB | 1625 | CON |
|  | 1.4.1.4.1.1.4.1.4.-1 | **2nd Fix** |  | 2019-08-28 | 2019-09-26 |  |  |  |  |  |  |  |  |  |  |
| A60722 |  | Valve and Accessories Installation | 20d | 2019-08-28 | 2019-09-15 | A60712, A60742 | 68.75d | 0d | Fire Fighting Crew [200 h] | 18.86 | MEP | 1 | MB | 1627 | CON |
| A60732 |  | Leak Test | 10d | 2019-09-16 | 2019-09-26 | A60722 | 68.75d | 29d | Fire Fighting Crew [100 h] | 9.43 | MEP | 1 | MB | 1631 | CON |
|  | 1.4.1.4.1.1.4.1.4.-2 | **FF_Final Fix** |  | 2019-10-30 | 2019-11-27 |  |  |  |  |  |  |  |  |  |  |
| A60752 |  | Installation of Sprinklers | 15d | 2019-10-30 | 2019-11-13 | A60712, A60722, A60732, 1F5-FNS-B03-620 | 40.75d | 0d | Fire Fighting Crew [150 h] | 14.15 | MEP | 1 | MB | 1633 | CON |
| A61092 |  | Installation of Fire hose Cabinet | 5d | 2019-11-13 | 2019-11-18 | A60712, A60752 | 90.75d | 0d | Fire Fighting Crew [50 h] | 4.71 | MEP | 1 | MB |  |  |
| A60762 |  | Instalaltion of Fire Extinguisher | 10d | 2019-11-18 | 2019-11-27 | A60712, A60752, A61092, LOE-SUM3-330 FF | 90.75d | 91.25d | Fire Fighting Crew [100 h] | 9.43 | MEP | 1 | MB |  | CON |
|  | 5 | **B03 - CONCOURSE ZONE 02** |  | 2019-06-30 | 2019-11-23 |  |  |  |  |  |  |  |  |  |  |
|  | 1.4.1.4.1.1.4.1.1 | **HVAC SYSTEM** |  | 2019-06-30 | 2019-11-13 |  |  |  |  |  |  |  |  |  |  |
|  | 1.4.1.4.1.1.4.1.1.1. | **1st Fix** |  | 2019-06-30 | 2019-07-16 |  |  |  |  |  |  |  |  |  |  |
| A62862 |  | Hanger and support Installation - Duct | 6d | 2019-06-30 | 2019-07-04 | RM180 | 8.25d | 0d | Mechanical Crew [60 h] | 5.66 | MEP | 2 | MB | 1546 | CON |
| A62932 |  | Hanger and support Installation - CHW | 6d | 2019-06-30 | 2019-07-04 | A62862 SS | 8.25d | 0d | Mechanical Crew [60 h] | 5.66 | MEP | 2 | MB |  |  |
| A62842 |  | Duct Installation | 12d | 2019-07-01 | 2019-07-13 | A62862 SS+2d | 130.25d | 0d | Duct Installation [260 Sqmt]; HVAC [780 h] | 73.55 | MEP | 2 | MB | 1549 | CON |
| A62852 |  | Duct Insulation | 8d | 2019-07-04 | 2019-07-11 | A62842 SS+3d | 154.25d | 113.5d | Duct Insulation [180 Sqmt]; HVAC [128 h] | 12.07 | MEP | 2 | MB | 1552 | CON |
| A62952 |  | Chilled Water Piping Installation | 12d | 2019-07-04 | 2019-07-16 | A62932 | 8.25d | 0d | Mechanical Crew [120 h] | 11.32 | MEP | 2 | MB |  |  |
|  | 1.4.1.4.1.1.4.1.1.-1 | **2nd Fix** |  | 2019-07-13 | 2019-08-04 |  |  |  |  |  |  |  |  |  |  |
| A62942 |  | Installation of Duct Accessories (VD, FD, MSD etc....) | 12d | 2019-07-13 | 2019-07-23 | A62842 | 141.25d | 100.5d | Mechanical Crew [120 h] | 11.32 | MEP | 2 | MB |  |  |
| A63042 |  | CRAC Units Installation | 15d | 2019-07-13 | 2019-07-27 | A62842 | 130.25d | 9d | Mechanical Crew [150 h] | 14.15 | MEP | 2 | MB |  |  |
| A63052 |  | FCU Installation | 15d | 2019-07-13 | 2019-07-27 | A62842 | 130.25d | 9d | Mechanical Crew [150 h] | 14.15 | MEP | 2 | MB |  |  |
| A63062 |  | VRF DX Units Installation | 12d | 2019-07-13 | 2019-07-23 | A62842 | 133.25d | 12d | Mechanical Crew [120 h] | 11.32 | MEP | 2 | MB |  |  |
| A63072 |  | Installation of Attenuators | 10d | 2019-07-13 | 2019-07-22 | A62842 | 135.25d | 14d | Mechanical Crew [100 h] | 9.43 | MEP | 2 | MB |  |  |
| A63082 |  | Installation of HVAC Fans | 10d | 2019-07-13 | 2019-07-22 | A62842 | 135.25d | 14d | Mechanical Crew [100 h] | 9.43 | MEP | 2 | MB |  |  |
| A63102 |  | Pressurization Unit | 8d | 2019-07-13 | 2019-07-20 | A62842 | 137.25d | 16d | Mechanical Crew [80 h] | 7.54 | MEP | 2 | MB |  |  |
| A63112 |  | Dosing pot | 5d | 2019-07-13 | 2019-07-17 | A62842 | 140.25d | 19d | Mechanical Crew [50 h] | 4.71 | MEP | 2 | MB |  |  |
| A63132 |  | Air Handling Units Installation | 12d | 2019-07-13 | 2019-07-23 | A62842 | 133.25d | 12d | Mechanical Crew [120 h] | 11.32 | MEP | 2 | MB |  |  |
| A62972 |  | Valves and Accessories | 10d | 2019-07-16 | 2019-07-25 | A62952 | 8.25d | 0d | Mechanical Crew [100 h] | 9.43 | MEP | 2 | MB |  |  |
| A63092 |  | Air-Cooled Chillers | 15d | 2019-07-16 | 2019-07-30 | A62952 | 126.25d | 5d | Mechanical Crew [150 h] | 14.15 | MEP | 2 | MB |  |  |
| A63142 |  | Chilled Water Pump Installation | 12d | 2019-07-16 | 2019-07-27 | A62952 | 129.25d | 8d | Mechanical Crew [120 h] | 11.32 | MEP | 2 | MB |  |  |
| A62982 |  | Chilled Water Pipe Insulation and Cladding | 10d | 2019-07-25 | 2019-08-04 | A62952, A62972 | 8.25d | 0d | Mechanical Crew [100 h] | 9.43 | MEP | 2 | MB |  |  |

| ID | WBS | Activity | Duration | Start | Finish | Predecessors | Total float | Free float | Resources | Cost | Discipline | AREA | LOCATION | MSP Activity ID | MEP-Phase |
| --- | --- | --- | --- | --- | --- | --- | --- | --- | --- | --- | --- | --- | --- | --- | --- |
|  | 1.4.1.4.1.1.4.1.1.-2 | **HVAC_Final Fix** |  | 2019-08-04 | 2019-11-13 |  |  |  |  |  |  |  |  |  |  |
| A63122 |  | Equuipment Connection | 8d | 2019-08-04 | 2019-08-14 | A63142, A63132, A63092, A63082, A63072, A63042, A63052, A63062, A63112, A63102, A62982 | 121.25d | 80.5d | Mechanical Crew [80 h] | 7.54 | MEP | 2 | MB |  |  |
| A62962 |  | Air Outlets (Grills, Diffusers, Registers etc...) | 15d | 2019-10-30 | 2019-11-13 | A62942, A62842, A62852, A63122, 1F5-FNS-B03-620 | 40.75d | 31.25d | Mechanical Crew [150 h] | 14.15 | MEP | 2 | MB |  |  |
|  | 1.4.1.4.1.1.4.1.2 | **PLUMBING SYSTEM** |  | 2019-06-30 | 2019-10-24 |  |  |  |  |  |  |  |  |  |  |
|  | 1.4.1.4.1.1.4.1.2.1. | **1st Fix** |  | 2019-06-30 | 2019-07-23 |  |  |  |  |  |  |  |  |  |  |
| A62722 |  | Hanger and support Installation | 10d | 2019-06-30 | 2019-07-08 | RM180 | 115.75d | 0d | Plumbing Crew [100 h] | 9.43 | MEP | 2 | MB | 1566 | CON |
| A62762 |  | Drainage and Vent Pipe & Fittings | 20d | 2019-07-04 | 2019-07-22 | A62722 SS+5d | 150.25d | 1d | Plumbing Crew [200 h] | 18.86 | MEP | 2 | MB | 1573 | CON |
| A62732 |  | Domestic Water Pipe & Fittings | 20d | 2019-07-04 | 2019-07-23 | A62722 SS+6d | 115.75d | 0d | Plumbing Crew [200 h] | 18.86 | MEP | 2 | MB | 1570 | CON |
|  | 1.4.1.4.1.1.4.1.2.-1 | **2nd Fix** |  | 2019-07-23 | 2019-08-07 |  |  |  |  |  |  |  |  |  |  |
| A62742 |  | Domestic Water Valves | 12d | 2019-07-23 | 2019-08-04 | A62732 | 115.75d | 0d | Plumbing Crew [120 h] | 11.32 | MEP | 2 | MB | 1571 | CON |
| A63002 |  | Sewege Pumps Installation | 5d | 2019-07-23 | 2019-07-28 | A62762, A62732 | 149.25d | 88d | Plumbing Crew [50 h] | 4.71 | MEP | 2 | MB |  |  |
| A62752 |  | Leak Test | 4d | 2019-08-04 | 2019-08-07 | A62742 | 115.75d | 62d | Plumbing Crew [40 h] | 3.77 | MEP | 2 | MB | 1572 | CON |
|  | 1.4.1.4.1.1.4.1.2.-2 | **PLM_Final Fix** |  | 2019-10-23 | 2019-10-24 |  |  |  |  |  |  |  |  |  |  |
| A62992 |  | Water Heaters | 2d | 2019-10-23 | 2019-10-24 | A62752, A62762, A62732, 1F5-FNS-B03-500 | 61.25d | 0d | Plumbing Crew [20 h] | 1.89 | MEP | 2 | MB |  |  |
| A63012 |  | Floor Drain | 2d | 2019-10-23 | 2019-10-24 | A62992 SS | 61.25d | 0d | Plumbing Crew [20 h] | 1.89 | MEP | 2 | MB |  |  |
| A63022 |  | Wash Basin / Water Closet | 2d | 2019-10-23 | 2019-10-24 | A63012 SS | 61.25d | 0d | Plumbing Crew [20 h] | 1.89 | MEP | 2 | MB |  |  |
| A63032 |  | Eye Wash | 2d | 2019-10-23 | 2019-10-24 | A63022 SS, A63002 | 61.25d | 38.75d | Plumbing Crew [20 h] | 1.89 | MEP | 2 | MB |  |  |
|  | 1.4.1.4.1.1.4.1.3 | **ELECTRICAL / CONTROLS** |  | 2019-06-30 | 2019-11-14 |  |  |  |  |  |  |  |  |  |  |
|  | 1.4.1.4.1.1.4.1.3.1. | **1st Fix** |  | 2019-06-30 | 2019-07-29 |  |  |  |  |  |  |  |  |  |  |
| A62822 |  | Installation of Conduits and Boxes | 12d | 2019-06-30 | 2019-07-10 | RM180 | 1.5d | 0d | Electrical Crew [120 h] | 11.32 | MEP | 2 | MB | 1592 | CON |
| A62832 |  | Installation of Cable Tray, Ladder and Trunk | 20d | 2019-07-10 | 2019-07-29 | A62822 | 114.25d | 0d | Electrical Crew [200 h] | 18.86 | MEP | 2 | MB | 1593 | CON |
|  | 1.4.1.4.1.1.4.1.3.-1 | **2nd Fix** |  | 2019-07-10 | 2019-10-09 |  |  |  |  |  |  |  |  |  |  |
| A62792 |  | Grounding and Bonding Installation | 20d | 2019-07-10 | 2019-07-29 | A62822 | 1.5d | 0d | Electrical Crew [200 h] | 18.86 | MEP | 2 | MB | 1596 | CON |
| A63152 |  | Wire Pulling | 20d | 2019-07-29 | 2019-08-20 | A62792 | 1.5d | 0d | Electrical Crew [200 h] | 18.86 | MEP | 2 | MB |  |  |
| A63212 |  | Installation of Bus Duct System | 20d | 2019-07-29 | 2019-08-20 | A62832 | 114.25d | 74.5d | Electrical Crew [200 h] | 18.86 | MEP | 2 | MB |  |  |
| A62772 |  | Power Cable Laying | 25d | 2019-08-20 | 2019-09-12 | A63152, A62792 | 1.5d | 0d | Electrical Crew [250 h] | 23.58 | MEP | 2 | MB | 1600 | CON |
| A62782 |  | Continuity Test - Power Cables | 4d | 2019-09-12 | 2019-09-16 | A62772 | 85.25d | 45.5d | Electrical Crew [40 h] | 3.77 | MEP | 2 | MB | 1601 | CON |
| A63162 |  | Installation of Central Battery Equipment | 6d | 2019-09-12 | 2019-09-18 | A62772, A63152 | 83.25d | 43.5d | Electrical Crew [60 h] | 5.66 | MEP | 2 | MB |  |  |
| A63172 |  | Installation of Disconnect Switch | 8d | 2019-09-12 | 2019-09-19 | A62772, A63152 | 81.25d | 41.5d | Electrical Crew [80 h] | 7.54 | MEP | 2 | MB |  |  |
| A63192 |  | Installation of Switch Boards (MDB, EMDB) | 15d | 2019-09-12 | 2019-09-28 | A62772, A63152 | 1.5d | 0d | Electrical Crew [150 h] | 14.15 | MEP | 2 | MB |  |  |
| A63202 |  | Installation of Panel Boards | 15d | 2019-09-12 | 2019-09-28 | A62772, A63152 | 53.75d | 0d | Electrical Crew [150 h] | 14.15 | MEP | 2 | MB |  |  |
| A63222 |  | Installation of MCC | 15d | 2019-09-12 | 2019-09-28 | A62772, A63152 | 53.75d | 0d | Electrical Crew [150 h] | 14.15 | MEP | 2 | MB |  |  |
| A63232 |  | Installation of Lighting Control System | 12d | 2019-09-12 | 2019-09-25 | A62772, A63152 | 56.75d | 3d | Electrical Crew [120 h] | 11.32 | MEP | 2 | MB |  |  |
| A63182 |  | Installation of Wiring Devices and Outlets | 12d | 2019-09-28 | 2019-10-09 | A63152, A63222, A63202, A63192, A63232 | 53.75d | 0d | Electrical Crew [120 h] | 11.32 | MEP | 2 | MB |  |  |

| ID | WBS | Activity | Type | Duration | Start | Finish | Predecessors | Total float | Free float | Calendar | Resources | Cost | Discipline | AREA | LOCATION | MSP Activity ID | MEP-Phase |
| --- | --- | --- | --- | --- | --- | --- | --- | --- | --- | --- | --- | --- | --- | --- | --- | --- | --- |
|  | 1.4.1.4.1.1.4.1.3.-2 | **Elec._Final Fix** |  |  | 2019-09-28 | 2019-11-14 |  |  |  |  |  |  |  |  |  |  |  |
| A63242 |  | Panel Board Termination |  | 8d | 2019-09-28 | 2019-10-06 | A63192, A63202, A63222 | 72.25d | 32.5d |  | Electrical Crew [80 h] | 7.54 | MEP | 2 | MB |  |  |
| A62812 |  | Wiring devices Termination |  | 6d | 2019-10-30 | 2019-11-05 | A63162, A63172, A63212, A63232, A63182, A62782, 1F5-FNS-B03-620 | 39.75d | 0d |  | Electrical Crew [60 h] | 5.66 | MEP | 2 | MB | 1617 | CON |
| A62802 |  | Lighting Fixtures Installation and Termination |  | 10d | 2019-11-05 | 2019-11-14 | A62772, A63152, A63242, A62812 | 39.75d | 25.25d |  | Electrical Crew [100 h] | 9.43 | MEP | 2 | MB | 1616 | CON |
|  | 1.4.1.4.1.1.4.1.4 | **FIRE FIGHTING SYSTEM** |  |  | 2019-06-30 | 2019-11-23 |  |  |  |  |  |  |  |  |  |  |  |
|  | 1.4.1.4.1.1.4.1.4.1. | **1st Fix** |  |  | 2019-06-30 | 2019-08-13 |  |  |  |  |  |  |  |  |  |  |  |
| A62902 |  | Fire Fighting Hangers & Supports |  | 15d | 2019-06-30 | 2019-07-13 | RM180 | 82.75d | 0d |  | Fire Fighting Crew [150 h] | 14.15 | MEP | 2 | MB | 1622 | CON |
| A62872 |  | Pipe Installation |  | 30d | 2019-07-14 | 2019-08-13 | A62902 | 82.75d | 0d |  | FF pipe [206 Limt]; FIRE FIGHTING [361 h] | 34.04 | MEP | 2 | MB | 1625 | CON |
|  | 1.4.1.4.1.1.4.1.4.-1 | **2nd Fix** |  |  | 2019-08-14 | 2019-09-10 |  |  |  |  |  |  |  |  |  |  |  |
| A62882 |  | Valve and Accessories Installation |  | 20d | 2019-08-14 | 2019-09-01 | A62872, A62902 | 82.75d | 0d |  | Fire Fighting Crew [200 h] | 18.86 | MEP | 2 | MB | 1627 | CON |
| A62892 |  | Leak Test |  | 10d | 2019-09-02 | 2019-09-10 | A62882 | 82.75d | 29d |  | Fire Fighting Crew [100 h] | 9.43 | MEP | 2 | MB | 1631 | CON |
|  | 1.4.1.4.1.1.4.1.4.-2 | **FF_Final Fix** |  |  | 2019-10-30 | 2019-11-23 |  |  |  |  |  |  |  |  |  |  |  |
| A62912 |  | Installation of Sprinklers |  | 15d | 2019-10-30 | 2019-11-13 | A62872, A62882, A62892, 1F5-FNS-B03-620 | 40.75d | 0d |  | Fire Fighting Crew [150 h] | 14.15 | MEP | 2 | MB | 1633 | CON |
| A62922 |  | Instalaltion of Fire Extinguisher |  | 10d | 2019-11-13 | 2019-11-23 | A62872, A62912, A63252 FF, LOE-SUM3-330 FF | 95.75d | 96.25d |  | Fire Fighting Crew [100 h] | 9.43 | MEP | 2 | MB |  | CON |
| A63252 |  | Installation of Fire hose Cabinet |  | 5d | 2019-11-13 | 2019-11-18 | A62872, A62912 | 100.75d | 5d |  | Fire Fighting Crew [50 h] | 4.71 | MEP | 2 | MB |  |  |
|  | 1.4.311 | **B02 - CONCOURSE MEZZ & TV LOUVER** |  |  | 2019-05-18 | 2019-12-22 |  |  |  |  |  |  |  |  |  |  |  |
|  | 7 | **SOUTH CONCOURSE MEZZ & TV LOUVER - ZONE 4 AND 5** |  |  | 2019-05-18 | 2019-10-14 |  |  |  |  |  |  |  |  |  |  |  |
| LOE-SUM3-340 |  | South . B02 - MEP Works; 1st & 2nd Fix | level of effort | 126.5d | 2019-05-18 | 2019-09-12 | RM210 | 84.25d | 0d | Saudi |  |  | MEP |  |  |  |  |
| LOE-SUM3-350 |  | South . B02 - MEP Works; Final fix | level of effort | 118.75d | 2019-06-25 | 2019-10-14 | LOE-SUM3-340, A67442 SS | 138.25d | 0d | Saudi |  |  | MEP |  |  |  |  |
|  | 1 | **B02 - CONCOURSE MEZZ & TV LOUVER - ZONE 04** |  |  | 2019-06-01 | 2019-10-14 |  |  |  |  |  |  |  |  |  |  |  |
|  | 1.4.1.4.1.1.4.1.1 | **HVAC SYSTEM** |  |  | 2019-06-01 | 2019-10-05 |  |  |  |  |  |  |  |  |  |  |  |
|  | 1.4.1.4.1.1.4.1.1.1. | **1st Fix** |  |  | 2019-06-01 | 2019-06-20 |  |  |  |  |  |  |  |  |  |  |  |
| A65022 |  | Hanger and support Installation - Duct |  | 6d | 2019-06-01 | 2019-06-09 | RM200 | 148.25d | 0d |  | Mechanical Crew [60 h] | 5.66 | MEP | 4 | MB | 1546 | CON |
| A65092 |  | Hanger and support Installation - CHW |  | 6d | 2019-06-01 | 2019-06-09 | A65022 SS | 148.25d | 0d |  | Mechanical Crew [60 h] | 5.66 | MEP | 4 | MB |  |  |
| A65002 |  | Duct Installation |  | 12d | 2019-06-02 | 2019-06-17 | A65022 SS+2d | 157.75d | 0d |  | Duct Installation [260 Sqmt]; HVAC [780 h] | 73.55 | MEP | 4 | MB | 1549 | CON |
| A65012 |  | Duct Insulation |  | 8d | 2019-06-09 | 2019-06-16 | A65002 SS+3d | 181.75d | 98.5d |  | Duct Insulation [263 Sqmt]; HVAC [190 h] | 17.92 | MEP | 4 | MB | 1552 | CON |
| A65112 |  | Chilled Water Piping Installation |  | 12d | 2019-06-09 | 2019-06-20 | A65092 | 148.25d | 0d |  | Mechanical Crew [120 h] | 11.32 | MEP | 4 | MB |  |  |

| ID | WBS | Activity | Duration | Start | Finish | Predecessors | Total float | Free float | Resources | Cost | Discipline | AREA | LOCATION | MSP Activity ID | MEP-Phase |
| --- | --- | --- | --- | --- | --- | --- | --- | --- | --- | --- | --- | --- | --- | --- | --- |
|  | 1.4.1.4.1.1.4.1.1.-1 | **2nd Fix** |  | 2019-06-17 | 2019-07-09 |  |  |  |  |  |  |  |  |  |  |
| A65102 |  | Installation of Duct Accessories (VD, FD, MSD etc....) | 12d | 2019-06-17 | 2019-06-27 | A65002 | 168.75d | 85.5d | Mechanical Crew [120 h] | 11.32 | MEP | 4 | MB |  |  |
| A65202 |  | CRAC Units Installation | 15d | 2019-06-17 | 2019-07-01 | A65002 | 157.75d | 9d | Mechanical Crew [150 h] | 14.15 | MEP | 4 | MB |  |  |
| A65212 |  | FCU Installation | 15d | 2019-06-17 | 2019-07-01 | A65002 | 157.75d | 9d | Mechanical Crew [150 h] | 14.15 | MEP | 4 | MB |  |  |
| A65222 |  | VRF DX Units Installation | 12d | 2019-06-17 | 2019-06-27 | A65002 | 160.75d | 12d | Mechanical Crew [120 h] | 11.32 | MEP | 4 | MB |  |  |
| A65232 |  | Installation of Attenuators | 10d | 2019-06-17 | 2019-06-26 | A65002 | 162.75d | 14d | Mechanical Crew [100 h] | 9.43 | MEP | 4 | MB |  |  |
| A65242 |  | Installation of HVAC Fans | 10d | 2019-06-17 | 2019-06-26 | A65002 | 162.75d | 14d | Mechanical Crew [100 h] | 9.43 | MEP | 4 | MB |  |  |
| A65262 |  | Pressurization Unit | 8d | 2019-06-17 | 2019-06-24 | A65002 | 164.75d | 16d | Mechanical Crew [80 h] | 7.54 | MEP | 4 | MB |  |  |
| A65272 |  | Dosing pot | 5d | 2019-06-17 | 2019-06-22 | A65002 | 167.75d | 19d | Mechanical Crew [50 h] | 4.71 | MEP | 4 | MB |  |  |
| A65292 |  | Air Handling Units Installation | 12d | 2019-06-17 | 2019-06-27 | A65002 | 160.75d | 12d | Mechanical Crew [120 h] | 11.32 | MEP | 4 | MB |  |  |
| A65132 |  | Valves and Accessories | 10d | 2019-06-20 | 2019-06-30 | A65112 | 148.25d | 0d | Mechanical Crew [100 h] | 9.43 | MEP | 4 | MB |  |  |
| A65252 |  | Air-Cooled Chillers | 15d | 2019-06-20 | 2019-07-04 | A65112 | 153.75d | 5d | Mechanical Crew [150 h] | 14.15 | MEP | 4 | MB |  |  |
| A65302 |  | Chilled Water Pump Installation | 12d | 2019-06-20 | 2019-07-01 | A65112 | 156.75d | 8d | Mechanical Crew [120 h] | 11.32 | MEP | 4 | MB |  |  |
| A65142 |  | Chilled Water Pipe Insulation and Cladding | 10d | 2019-06-30 | 2019-07-09 | A65112, A65132 | 148.25d | 0d | Mechanical Crew [100 h] | 9.43 | MEP | 4 | MB |  |  |
|  | 1.4.1.4.1.1.4.1.1.-2 | **HVAC_Final Fix** |  | 2019-07-09 | 2019-10-05 |  |  |  |  |  |  |  |  |  |  |
| A65282 |  | Equuipment Connection | 8d | 2019-07-09 | 2019-07-16 | A65302, A65292, A65252, A65242, A65232, A65202, A65212, A65222, A65272, A65262, A65142 | 148.75d | 65.5d | Mechanical Crew [80 h] | 7.54 | MEP | 4 | MB |  |  |
| A65122 |  | Air Outlets (Grills, Diffusers, Registers etc...) | 15d | 2019-09-19 | 2019-10-05 | A65102, A65002, A65012, A65282, 1F5-FNS-B02-240 | 83.25d | 73.75d | Mechanical Crew [150 h] | 14.15 | MEP | 4 | MB |  |  |
|  | 1.4.1.4.1.1.4.1.2 | **PLUMBING SYSTEM** |  | 2019-06-01 | 2019-09-29 |  |  |  |  |  |  |  |  |  |  |
|  | 1.4.1.4.1.1.4.1.2.1. | **1st Fix** |  | 2019-06-01 | 2019-06-27 |  |  |  |  |  |  |  |  |  |  |
| A64882 |  | Hanger and support Installation | 10d | 2019-06-01 | 2019-06-12 | RM200 | 144.25d | 0d | Plumbing Crew [100 h] | 9.43 | MEP | 4 | MB | 1566 | CON |
| A64922 |  | Drainage and Vent Pipe & Fittings | 20d | 2019-06-09 | 2019-06-26 | A64882 SS+5d | 177.75d | 1d | Plumbing Crew [200 h] | 18.86 | MEP | 4 | MB | 1573 | CON |
| A64892 |  | Domestic Water Pipe & Fittings | 20d | 2019-06-09 | 2019-06-27 | A64882 SS+6d | 144.25d | 0d | Plumbing Crew [200 h] | 18.86 | MEP | 4 | MB | 1570 | CON |
|  | 1.4.1.4.1.1.4.1.2.-1 | **2nd Fix** |  | 2019-06-27 | 2019-07-13 |  |  |  |  |  |  |  |  |  |  |
| A64902 |  | Domestic Water Valves | 12d | 2019-06-27 | 2019-07-09 | A64892 | 144.25d | 0d | Plumbing Crew [120 h] | 11.32 | MEP | 4 | MB | 1571 | CON |
| A65162 |  | Sewege Pumps Installation | 5d | 2019-06-27 | 2019-07-02 | A64922, A64892 | 176.75d | 88d | Plumbing Crew [50 h] | 4.71 | MEP | 4 | MB |  |  |
| A64912 |  | Leak Test | 4d | 2019-07-09 | 2019-07-13 | A64902 | 144.25d | 62d | Plumbing Crew [40 h] | 3.77 | MEP | 4 | MB | 1572 | CON |

| ID | WBS | Activity | Duration | Start | Finish | Predecessors | Total float | Free float | Resources | Cost | Discipline | AREA | LOCATION | MSP Activity ID | MEP-Phase |
| --- | --- | --- | --- | --- | --- | --- | --- | --- | --- | --- | --- | --- | --- | --- | --- |
|  | 1.4.1.4.1.1.4.1.2.-2 | **PLM_Final Fix** |  | 2019-09-28 | 2019-09-29 |  |  |  |  |  |  |  |  |  |  |
| A65152 |  | Water Heaters | 2d | 2019-09-28 | 2019-09-29 | A64912, A64922, A64892, 1F5-FNS-B02-250 | 88.75d | 0d | Plumbing Crew [20 h] | 1.89 | MEP | 4 | MB |  |  |
| A65172 |  | Floor Drain | 2d | 2019-09-28 | 2019-09-29 | A65152 SS | 88.75d | 0d | Plumbing Crew [20 h] | 1.89 | MEP | 4 | MB |  |  |
| A65182 |  | Wash Basin / Water Closet | 2d | 2019-09-28 | 2019-09-29 | A65172 SS | 88.75d | 0d | Plumbing Crew [20 h] | 1.89 | MEP | 4 | MB |  |  |
| A65192 |  | Eye Wash | 2d | 2019-09-28 | 2019-09-29 | A65182 SS, A65162 | 88.75d | 66.25d | Plumbing Crew [20 h] | 1.89 | MEP | 4 | MB |  |  |
|  | 1.4.1.4.1.1.4.1.3 | **ELECTRICAL / CONTROLS** |  | 2019-06-01 | 2019-10-06 |  |  |  |  |  |  |  |  |  |  |
|  | 1.4.1.4.1.1.4.1.3.1. | **1st Fix** |  | 2019-06-01 | 2019-07-03 |  |  |  |  |  |  |  |  |  |  |
| A64982 |  | Installation of Conduits and Boxes | 12d | 2019-06-01 | 2019-06-15 | RM200 | 82.25d | 0d | Electrical Crew [120 h] | 11.32 | MEP | 4 | MB | 1592 | CON |
| A64992 |  | Installation of Cable Tray, Ladder and Trunk | 20d | 2019-06-15 | 2019-07-03 | A64982 | 141.75d | 0d | Electrical Crew [200 h] | 18.86 | MEP | 4 | MB | 1593 | CON |
|  | 1.4.1.4.1.1.4.1.3.-1 | **2nd Fix** |  | 2019-06-15 | 2019-09-12 |  |  |  |  |  |  |  |  |  |  |
| A64952 |  | Grounding and Bonding Installation | 20d | 2019-06-15 | 2019-07-03 | A64982 | 82.25d | 0d | Electrical Crew [200 h] | 18.86 | MEP | 4 | MB | 1596 | CON |
| A65312 |  | Wire Pulling | 20d | 2019-07-03 | 2019-07-22 | A64952 | 82.25d | 0d | Electrical Crew [200 h] | 18.86 | MEP | 4 | MB |  |  |
| A65372 |  | Installation of Bus Duct System | 20d | 2019-07-03 | 2019-07-22 | A64992 | 141.75d | 59.5d | Electrical Crew [200 h] | 18.86 | MEP | 4 | MB |  |  |
| A64932 |  | Power Cable Laying | 25d | 2019-07-22 | 2019-08-18 | A65312, A64952 | 82.25d | 0d | Electrical Crew [250 h] | 23.58 | MEP | 4 | MB | 1600 | CON |
| A64942 |  | Continuity Test - Power Cables | 4d | 2019-08-18 | 2019-08-21 | A64932 | 112.75d | 30.5d | Electrical Crew [40 h] | 3.77 | MEP | 4 | MB | 1601 | CON |
| A65322 |  | Installation of Central Battery Equipment | 6d | 2019-08-18 | 2019-08-24 | A64932, A65312 | 110.75d | 28.5d | Electrical Crew [60 h] | 5.66 | MEP | 4 | MB |  |  |
| A65332 |  | Installation of Disconnect Switch | 8d | 2019-08-18 | 2019-08-25 | A64932, A65312 | 108.75d | 26.5d | Electrical Crew [80 h] | 7.54 | MEP | 4 | MB |  |  |
| A65352 |  | Installation of Switch Boards (MDB, EMDB) | 15d | 2019-08-18 | 2019-09-01 | A64932, A65312 | 82.25d | 0d | Electrical Crew [150 h] | 14.15 | MEP | 4 | MB |  |  |
| A65362 |  | Installation of Panel Boards | 15d | 2019-08-18 | 2019-09-01 | A64932, A65312 | 82.25d | 0d | Electrical Crew [150 h] | 14.15 | MEP | 4 | MB |  |  |
| A65382 |  | Installation of MCC | 15d | 2019-08-18 | 2019-09-01 | A64932, A65312 | 82.25d | 0d | Electrical Crew [150 h] | 14.15 | MEP | 4 | MB |  |  |
| A65392 |  | Installation of Lighting Control System | 12d | 2019-08-18 | 2019-08-29 | A64932, A65312 | 85.25d | 3d | Electrical Crew [120 h] | 11.32 | MEP | 4 | MB |  |  |
| A65342 |  | Installation of Wiring Devices and Outlets | 12d | 2019-09-01 | 2019-09-12 | A65312, A65382, A65362, A65352, A65392 | 82.25d | 0d | Electrical Crew [120 h] | 11.32 | MEP | 4 | MB |  |  |
|  | 1.4.1.4.1.1.4.1.3.-2 | **Elec._Final Fix** |  | 2019-09-01 | 2019-10-06 |  |  |  |  |  |  |  |  |  |  |
| A65402 |  | Panel Board Termination | 8d | 2019-09-01 | 2019-09-08 | A65352, A65362, A65382 | 99.75d | 17.5d | Electrical Crew [80 h] | 7.54 | MEP | 4 | MB |  |  |
| A64972 |  | Wiring devices Termination | 6d | 2019-09-19 | 2019-09-26 | A65322, A65332, A65372, A65392, A65342, A64942, 1F5-FNS-B02-240 | 82.25d | 0d | Electrical Crew [60 h] | 5.66 | MEP | 4 | MB | 1617 | CON |
| A64962 |  | Lighting Fixtures Installation and Termination | 10d | 2019-09-26 | 2019-10-06 | A64932, A65312, A65402, A64972, LOE-SUM3-350 FF | 82.25d | 67.75d | Electrical Crew [100 h] | 9.43 | MEP | 4 | MB | 1616 | CON |

| ID | WBS | Activity | Duration | Start | Finish | Predecessors | Total float | Free float | Resources | Cost | MSP Activity ID | Discipline | MEP-Phase | AREA | LOCATION |
| --- | --- | --- | --- | --- | --- | --- | --- | --- | --- | --- | --- | --- | --- | --- | --- |
|  | 1.4.1.4.1.1.4.1.4 | **FIRE FIGHTING SYSTEM** |  | 2019-06-01 | 2019-10-14 |  |  |  |  |  |  |  |  |  |  |
|  | 1.4.1.4.1.1.4.1.4.1. | **1st Fix** |  | 2019-06-01 | 2019-07-15 |  |  |  |  |  |  |  |  |  |  |
| A65062 |  | Fire Fighting Hangers & Supports | 15d | 2019-06-01 | 2019-06-17 | RM200 | 111.25d | 0d | Fire Fighting Crew [150 h] | 14.15 | 1622 | MEP | CON | 4 | MB |
| A65032 |  | Pipe Installation | 30d | 2019-06-18 | 2019-07-15 | A65062 | 111.25d | 0d | FIRE FIGHTING [361 h]; FF pipe [206 Limt] | 34.04 | 1625 | MEP | CON | 4 | MB |
|  | 1.4.1.4.1.1.4.1.4.-1 | **2nd Fix** |  | 2019-07-16 | 2019-08-15 |  |  |  |  |  |  |  |  |  |  |
| A65042 |  | Valve and Accessories Installation | 20d | 2019-07-16 | 2019-08-03 | A65032, A65062 | 111.25d | 0d | Fire Fighting Crew [200 h] | 18.86 | 1627 | MEP | CON | 4 | MB |
| A65052 |  | Leak Test | 10d | 2019-08-04 | 2019-08-15 | A65042 | 111.25d | 29d | Fire Fighting Crew [100 h] | 9.43 | 1631 | MEP | CON | 4 | MB |
|  | 1.4.1.4.1.1.4.1.4.-2 | **FF_Final Fix** |  | 2019-09-19 | 2019-10-14 |  |  |  |  |  |  |  |  |  |  |
| A65072 |  | Installation of Sprinklers | 15d | 2019-09-19 | 2019-10-05 | A65032, A65042, A65052, 1F5-FNS-B02-240 | 83.25d | 0d | Fire Fighting Crew [150 h] | 14.15 | 1633 | MEP | CON | 4 | MB |
| A65082 |  | Instalaltion of Fire Extinguisher | 10d | 2019-10-05 | 2019-10-14 | A65032, A65072, A65412 FF, LOE-SUM3-350 FF | 138.25d | 138.75d | Fire Fighting Crew [100 h] | 9.43 |  | MEP | CON | 4 | MB |
| A65412 |  | Installation of Fire hose Cabinet | 5d | 2019-10-05 | 2019-10-09 | A65032, A65072 | 143.25d | 5d | Fire Fighting Crew [50 h] | 4.71 |  | MEP |  | 4 | MB |
|  | 2 | **B02 - CONCOURSE MEZZ & TV LOUVER - ZONE 05** |  | 2019-05-18 | 2019-09-30 |  |  |  |  |  |  |  |  |  |  |
|  | 1.4.1.4.1.1.4.1.1 | **HVAC SYSTEM** |  | 2019-05-18 | 2019-09-19 |  |  |  |  |  |  |  |  |  |  |
|  | 1.4.1.4.1.1.4.1.1.1. | **1st Fix** |  | 2019-05-18 | 2019-06-03 |  |  |  |  |  |  |  |  |  |  |
| A67182 |  | Hanger and support Installation - Duct | 6d | 2019-05-18 | 2019-05-22 | RM210 | 163.25d | 0d | Mechanical Crew [60 h] | 5.66 | 1546 | MEP | CON | 5 | MB |
| A67252 |  | Hanger and support Installation - CHW | 6d | 2019-05-18 | 2019-05-22 | A67182 SS | 163.25d | 0d | Mechanical Crew [60 h] | 5.66 |  | MEP |  | 5 | MB |
| A67162 |  | Duct Installation | 12d | 2019-05-19 | 2019-05-30 | A67182 SS+2d | 172.75d | 0d | Duct Installation [260 Sqmt]; HVAC [780 h] | 73.55 | 1549 | MEP | CON | 5 | MB |
| A67172 |  | Duct Insulation | 8d | 2019-05-22 | 2019-05-29 | A67162 SS+3d | 196.75d | 98.5d | Duct Insulation [263 Sqmt]; HVAC [190 h] | 17.92 | 1552 | MEP | CON | 5 | MB |
| A67272 |  | Chilled Water Piping Installation | 12d | 2019-05-22 | 2019-06-03 | A67252 | 163.25d | 0d | Mechanical Crew [120 h] | 11.32 |  | MEP |  | 5 | MB |
|  | 1.4.1.4.1.1.4.1.1.-1 | **2nd Fix** |  | 2019-05-30 | 2019-06-25 |  |  |  |  |  |  |  |  |  |  |
| A67262 |  | Installation of Duct Accessories (VD, FD, MSD etc....) | 12d | 2019-05-30 | 2019-06-13 | A67162 | 183.75d | 85.5d | Mechanical Crew [120 h] | 11.32 |  | MEP |  | 5 | MB |
| A67362 |  | CRAC Units Installation | 15d | 2019-05-30 | 2019-06-17 | A67162 | 172.75d | 9d | Mechanical Crew [150 h] | 14.15 |  | MEP |  | 5 | MB |
| A67372 |  | FCU Installation | 15d | 2019-05-30 | 2019-06-17 | A67162 | 172.75d | 9d | Mechanical Crew [150 h] | 14.15 |  | MEP |  | 5 | MB |
| A67382 |  | VRF DX Units Installation | 12d | 2019-05-30 | 2019-06-13 | A67162 | 175.75d | 12d | Mechanical Crew [120 h] | 11.32 |  | MEP |  | 5 | MB |
| A67392 |  | Installation of Attenuators | 10d | 2019-05-30 | 2019-06-12 | A67162 | 177.75d | 14d | Mechanical Crew [100 h] | 9.43 |  | MEP |  | 5 | MB |
| A67402 |  | Installation of HVAC Fans | 10d | 2019-05-30 | 2019-06-12 | A67162 | 177.75d | 14d | Mechanical Crew [100 h] | 9.43 |  | MEP |  | 5 | MB |
| A67422 |  | Pressurization Unit | 8d | 2019-05-30 | 2019-06-10 | A67162 | 179.75d | 16d | Mechanical Crew [80 h] | 7.54 |  | MEP |  | 5 | MB |
| A67432 |  | Dosing pot | 5d | 2019-05-30 | 2019-06-08 | A67162 | 182.75d | 19d | Mechanical Crew [50 h] | 4.71 |  | MEP |  | 5 | MB |
| A67452 |  | Air Handling Units Installation | 12d | 2019-05-30 | 2019-06-13 | A67162 | 175.75d | 12d | Mechanical Crew [120 h] | 11.32 |  | MEP |  | 5 | MB |
| A67292 |  | Valves and Accessories | 10d | 2019-06-03 | 2019-06-16 | A67272 | 163.25d | 0d | Mechanical Crew [100 h] | 9.43 |  | MEP |  | 5 | MB |
| A67412 |  | Air-Cooled Chillers | 15d | 2019-06-03 | 2019-06-20 | A67272 | 168.75d | 5d | Mechanical Crew [150 h] | 14.15 |  | MEP |  | 5 | MB |
| A67462 |  | Chilled Water Pump Installation | 12d | 2019-06-03 | 2019-06-17 | A67272 | 171.75d | 8d | Mechanical Crew [120 h] | 11.32 |  | MEP |  | 5 | MB |
| A67302 |  | Chilled Water Pipe Insulation and Cladding | 10d | 2019-06-16 | 2019-06-25 | A67272, A67292 | 163.25d | 0d | Mechanical Crew [100 h] | 9.43 |  | MEP |  | 5 | MB |

| ID | WBS | Activity | Duration | Start | Finish | Predecessors | Total float | Free float | Resources | Cost | Discipline | AREA | LOCATION | MSP Activity ID | MEP-Phase |
| --- | --- | --- | --- | --- | --- | --- | --- | --- | --- | --- | --- | --- | --- | --- | --- |
|  | 1.4.1.4.1.1.4.1.1.-2 | **HVAC_Final Fix** |  | 2019-06-25 | 2019-09-19 |  |  |  |  |  |  |  |  |  |  |
| A67442 |  | Equuipment Connection | 8d | 2019-06-25 | 2019-07-02 | A67462, A67452, A67412, A67402, A67392, A67362, A67372, A67382, A67432, A67422, A67302 | 163.75d | 65.5d | Mechanical Crew [80 h] | 7.54 | MEP | 5 | MB |  |  |
| A67282 |  | Air Outlets (Grills, Diffusers, Registers etc...) | 15d | 2019-09-05 | 2019-09-19 | A67262, A67162, A67172, A67442, 1F5-FNS-B02-100 | 98.25d | 88.75d | Mechanical Crew [150 h] | 14.15 | MEP | 5 | MB |  |  |
|  | 1.4.1.4.1.1.4.1.2 | **PLUMBING SYSTEM** |  | 2019-05-18 | 2019-09-14 |  |  |  |  |  |  |  |  |  |  |
|  | 1.4.1.4.1.1.4.1.2.1. | **1st Fix** |  | 2019-05-18 | 2019-06-13 |  |  |  |  |  |  |  |  |  |  |
| A67042 |  | Hanger and support Installation | 10d | 2019-05-18 | 2019-05-26 | RM210 | 159.25d | 0d | Plumbing Crew [100 h] | 9.43 | MEP | 5 | MB | 1566 | CON |
| A67082 |  | Drainage and Vent Pipe & Fittings | 20d | 2019-05-22 | 2019-06-12 | A67042 SS+5d | 192.75d | 1d | Plumbing Crew [200 h] | 18.86 | MEP | 5 | MB | 1573 | CON |
| A67052 |  | Domestic Water Pipe & Fittings | 20d | 2019-05-22 | 2019-06-13 | A67042 SS+6d | 159.25d | 0d | Plumbing Crew [200 h] | 18.86 | MEP | 5 | MB | 1570 | CON |
|  | 1.4.1.4.1.1.4.1.2.-1 | **2nd Fix** |  | 2019-06-13 | 2019-06-29 |  |  |  |  |  |  |  |  |  |  |
| A67062 |  | Domestic Water Valves | 12d | 2019-06-13 | 2019-06-25 | A67052 | 159.25d | 0d | Plumbing Crew [120 h] | 11.32 | MEP | 5 | MB | 1571 | CON |
| A67322 |  | Sewege Pumps Installation | 5d | 2019-06-13 | 2019-06-18 | A67082, A67052 | 191.75d | 88d | Plumbing Crew [50 h] | 4.71 | MEP | 5 | MB |  |  |
| A67072 |  | Leak Test | 4d | 2019-06-25 | 2019-06-29 | A67062 | 159.25d | 62d | Plumbing Crew [40 h] | 3.77 | MEP | 5 | MB | 1572 | CON |
|  | 1.4.1.4.1.1.4.1.2.-2 | **PLM_Final Fix** |  | 2019-09-12 | 2019-09-14 |  |  |  |  |  |  |  |  |  |  |
| A67312 |  | Water Heaters | 2d | 2019-09-12 | 2019-09-14 | A67072, A67082, A67052, 1F5-FNS-B02-110 | 103.75d | 0d | Plumbing Crew [20 h] | 1.89 | MEP | 5 | MB |  |  |
| A67332 |  | Floor Drain | 2d | 2019-09-12 | 2019-09-14 | A67312 SS | 103.75d | 0d | Plumbing Crew [20 h] | 1.89 | MEP | 5 | MB |  |  |
| A67342 |  | Wash Basin / Water Closet | 2d | 2019-09-12 | 2019-09-14 | A67332 SS | 103.75d | 0d | Plumbing Crew [20 h] | 1.89 | MEP | 5 | MB |  |  |
| A67352 |  | Eye Wash | 2d | 2019-09-12 | 2019-09-14 | A67342 SS, A67322 | 103.75d | 81.25d | Plumbing Crew [20 h] | 1.89 | MEP | 5 | MB |  |  |
|  | 1.4.1.4.1.1.4.1.3 | **ELECTRICAL / CONTROLS** |  | 2019-05-18 | 2019-09-19 |  |  |  |  |  |  |  |  |  |  |
|  | 1.4.1.4.1.1.4.1.3.1. | **1st Fix** |  | 2019-05-18 | 2019-06-19 |  |  |  |  |  |  |  |  |  |  |
| A67142 |  | Installation of Conduits and Boxes | 12d | 2019-05-18 | 2019-05-28 | RM210 | 97.25d | 0d | Electrical Crew [120 h] | 11.32 | MEP | 5 | MB | 1592 | CON |
| A67152 |  | Installation of Cable Tray, Ladder and Trunk | 20d | 2019-05-28 | 2019-06-19 | A67142 | 156.75d | 0d | Electrical Crew [200 h] | 18.86 | MEP | 5 | MB | 1593 | CON |
|  | 1.4.1.4.1.1.4.1.3.-1 | **2nd Fix** |  | 2019-05-28 | 2019-08-29 |  |  |  |  |  |  |  |  |  |  |
| A67112 |  | Grounding and Bonding Installation | 20d | 2019-05-28 | 2019-06-19 | A67142 | 97.25d | 0d | Electrical Crew [200 h] | 18.86 | MEP | 5 | MB | 1596 | CON |
| A67472 |  | Wire Pulling | 20d | 2019-06-19 | 2019-07-08 | A67112 | 97.25d | 0d | Electrical Crew [200 h] | 18.86 | MEP | 5 | MB |  |  |
| A67532 |  | Installation of Bus Duct System | 20d | 2019-06-19 | 2019-07-08 | A67152 | 156.75d | 59.5d | Electrical Crew [200 h] | 18.86 | MEP | 5 | MB |  |  |
| A67092 |  | Power Cable Laying | 25d | 2019-07-08 | 2019-07-31 | A67472, A67112 | 97.25d | 0d | Electrical Crew [250 h] | 23.58 | MEP | 5 | MB | 1600 | CON |
| A67102 |  | Continuity Test - Power Cables | 4d | 2019-07-31 | 2019-08-04 | A67092 | 127.75d | 30.5d | Electrical Crew [40 h] | 3.77 | MEP | 5 | MB | 1601 | CON |
| A67482 |  | Installation of Central Battery Equipment | 6d | 2019-07-31 | 2019-08-06 | A67092, A67472 | 125.75d | 28.5d | Electrical Crew [60 h] | 5.66 | MEP | 5 | MB |  |  |
| A67492 |  | Installation of Disconnect Switch | 8d | 2019-07-31 | 2019-08-07 | A67092, A67472 | 123.75d | 26.5d | Electrical Crew [80 h] | 7.54 | MEP | 5 | MB |  |  |
| A67512 |  | Installation of Switch Boards (MDB, EMDB) | 15d | 2019-07-31 | 2019-08-18 | A67092, A67472 | 97.25d | 0d | Electrical Crew [150 h] | 14.15 | MEP | 5 | MB |  |  |
| A67522 |  | Installation of Panel Boards | 15d | 2019-07-31 | 2019-08-18 | A67092, A67472 | 97.25d | 0d | Electrical Crew [150 h] | 14.15 | MEP | 5 | MB |  |  |
| A67542 |  | Installation of MCC | 15d | 2019-07-31 | 2019-08-18 | A67092, A67472 | 97.25d | 0d | Electrical Crew [150 h] | 14.15 | MEP | 5 | MB |  |  |
| A67552 |  | Installation of Lighting Control System | 12d | 2019-07-31 | 2019-08-15 | A67092, A67472 | 100.25d | 3d | Electrical Crew [120 h] | 11.32 | MEP | 5 | MB |  |  |
| A67502 |  | Installation of Wiring Devices and Outlets | 12d | 2019-08-18 | 2019-08-29 | A67472, A67542, A67522, A67512, A67552 | 97.25d | 0d | Electrical Crew [120 h] | 11.32 | MEP | 5 | MB |  |  |

| ID | WBS | Activity | Type | Duration | Start | Finish | Predecessors | Total float | Free float | Calendar | Resources | Cost | Discipline | AREA | LOCATION | MSP Activity ID | MEP-Phase |
| --- | --- | --- | --- | --- | --- | --- | --- | --- | --- | --- | --- | --- | --- | --- | --- | --- | --- |
|  | 1.4.1.4.1.1.4.1.3.-2 | **Elec._Final Fix** |  |  | 2019-08-18 | 2019-09-19 |  |  |  |  |  |  |  |  |  |  |  |
| A67562 |  | Panel Board Termination |  | 8d | 2019-08-18 | 2019-08-25 | A67512, A67522, A67542 | 114.75d | 17.5d |  | Electrical Crew [80 h] | 7.54 | MEP | 5 | MB |  |  |
| A67132 |  | Wiring devices Termination |  | 6d | 2019-09-05 | 2019-09-10 | A67482, A67492, A67532, A67552, A67502, A67102, 1F5-FNS-B02-100 | 97.25d | 0d |  | Electrical Crew [60 h] | 5.66 | MEP | 5 | MB | 1617 | CON |
| A67122 |  | Lighting Fixtures Installation and Termination |  | 10d | 2019-09-11 | 2019-09-19 | A67092, A67472, A67132, A67562 | 97.25d | 82.75d |  | Electrical Crew [100 h] | 9.43 | MEP | 5 | MB | 1616 | CON |
|  | 1.4.1.4.1.1.4.1.4 | **FIRE FIGHTING SYSTEM** |  |  | 2019-05-18 | 2019-09-30 |  |  |  |  |  |  |  |  |  |  |  |
|  | 1.4.1.4.1.1.4.1.4.1. | **1st Fix** |  |  | 2019-05-18 | 2019-07-01 |  |  |  |  |  |  |  |  |  |  |  |
| A67222 |  | Fire Fighting Hangers & Supports |  | 15d | 2019-05-18 | 2019-05-30 | RM210 | 126.25d | 0d |  | Fire Fighting Crew [150 h] | 14.15 | MEP | 5 | MB | 1622 | CON |
| A67192 |  | Pipe Installation |  | 30d | 2019-06-01 | 2019-07-01 | A67222 | 126.25d | 0d |  | FF pipe [206 Limt]; FIRE FIGHTING [361 h] | 34.04 | MEP | 5 | MB | 1625 | CON |
|  | 1.4.1.4.1.1.4.1.4.-1 | **2nd Fix** |  |  | 2019-07-02 | 2019-07-29 |  |  |  |  |  |  |  |  |  |  |  |
| A67202 |  | Valve and Accessories Installation |  | 20d | 2019-07-02 | 2019-07-20 | A67192, A67222 | 126.25d | 0d |  | Fire Fighting Crew [200 h] | 18.86 | MEP | 5 | MB | 1627 | CON |
| A67212 |  | Leak Test |  | 10d | 2019-07-21 | 2019-07-29 | A67202 | 126.25d | 29d |  | Fire Fighting Crew [100 h] | 9.43 | MEP | 5 | MB | 1631 | CON |
|  | 1.4.1.4.1.1.4.1.4.-2 | **FF_Final Fix** |  |  | 2019-09-05 | 2019-09-30 |  |  |  |  |  |  |  |  |  |  |  |
| A67232 |  | Installation of Sprinklers |  | 15d | 2019-09-05 | 2019-09-19 | A67192, A67202, A67212, 1F5-FNS-B02-100 | 98.25d | 0d |  | Fire Fighting Crew [150 h] | 14.15 | MEP | 5 | MB | 1633 | CON |
| A67242 |  | Instalaltion of Fire Extinguisher |  | 10d | 2019-09-19 | 2019-09-30 | A67192, A67232, A67572 FF | 153.25d | 153.75d |  | Fire Fighting Crew [100 h] | 9.43 | MEP | 5 | MB |  | CON |
| A67572 |  | Installation of Fire hose Cabinet |  | 5d | 2019-09-19 | 2019-09-25 | A67192, A67232 | 158.25d | 5d |  | Fire Fighting Crew [50 h] | 4.71 | MEP | 5 | MB |  |  |
|  | 6 | **CENTRAL CONCOURSE MEZZ & TV LOUVER - ZONE 03** |  |  | 2019-07-15 | 2019-11-24 |  |  |  |  |  |  |  |  |  |  |  |
| LOE-SUM3-360 |  | Central . B02 - MEP Works; 1st & 2nd Fix | level of effort | 109.25d | 2019-07-15 | 2019-10-24 | RM220 | 39d | 0d | Saudi |  |  | MEP |  |  |  |  |
| LOE-SUM3-370 |  | Central . B02 - MEP Works; Final fix | level of effort | 100d | 2019-08-22 | 2019-11-24 | LOE-SUM3-360, A69602 SS | 94.5d | 0d | Saudi |  |  | MEP |  |  |  |  |
|  | 3 | **B02 - CONCOURSE MEZZ & TV LOUVER - ZONE 03** |  |  | 2019-07-15 | 2019-11-24 |  |  |  |  |  |  |  |  |  |  |  |
|  | 1.4.1.4.1.1.4.1.1 | **HVAC SYSTEM** |  |  | 2019-07-15 | 2019-11-14 |  |  |  |  |  |  |  |  |  |  |  |
|  | 1.4.1.4.1.1.4.1.1.1. | **1st Fix** |  |  | 2019-07-15 | 2019-07-31 |  |  |  |  |  |  |  |  |  |  |  |
| A69342 |  | Hanger and support Installation - Duct |  | 6d | 2019-07-15 | 2019-07-20 | RM220 | 103.5d | 0d |  | Mechanical Crew [60 h] | 5.66 | MEP | 3 | MB | 1546 | CON |
| A69412 |  | Hanger and support Installation - CHW |  | 6d | 2019-07-15 | 2019-07-20 | A69342 SS | 103.5d | 0d |  | Mechanical Crew [60 h] | 5.66 | MEP | 3 | MB |  |  |
| A69322 |  | Duct Installation |  | 12d | 2019-07-16 | 2019-07-28 | A69342 SS+2d | 114d | 0d |  | Duct Installation [520 Sqmt]; HVAC [1560 h] | 147.11 | MEP | 3 | MB | 1549 | CON |
| A69332 |  | Duct Insulation |  | 8d | 2019-07-20 | 2019-07-27 | A69322 SS+3d | 138d | 98.5d |  | Duct Insulation [535 Sqmt]; HVAC [380 h] | 35.83 | MEP | 3 | MB | 1552 | CON |
| A69432 |  | Chilled Water Piping Installation |  | 12d | 2019-07-20 | 2019-07-31 | A69412 | 103.5d | 0d |  | Mechanical Crew [120 h] | 11.32 | MEP | 3 | MB |  |  |

| ID | WBS | Activity | Duration | Start | Finish | Predecessors | Total float | Free float | Resources | Cost | Discipline | AREA | LOCATION | MSP Activity ID | MEP-Phase |
| --- | --- | --- | --- | --- | --- | --- | --- | --- | --- | --- | --- | --- | --- | --- | --- |
|  | 1.4.1.4.1.1.4.1.1.-1 | **2nd Fix** |  | 2019-07-28 | 2019-08-22 |  |  |  |  |  |  |  |  |  |  |
| A69422 |  | Installation of Duct Accessories (VD, FD, MSD etc....) | 12d | 2019-07-28 | 2019-08-07 | A69322 | 125d | 85.5d | Mechanical Crew [120 h] | 11.32 | MEP | 3 | MB |  |  |
| A69522 |  | CRAC Units Installation | 15d | 2019-07-28 | 2019-08-14 | A69322 | 114d | 9d | Mechanical Crew [150 h] | 14.15 | MEP | 3 | MB |  |  |
| A69532 |  | FCU Installation | 15d | 2019-07-28 | 2019-08-14 | A69322 | 114d | 9d | Mechanical Crew [150 h] | 14.15 | MEP | 3 | MB |  |  |
| A69542 |  | VRF DX Units Installation | 12d | 2019-07-28 | 2019-08-07 | A69322 | 117d | 12d | Mechanical Crew [120 h] | 11.32 | MEP | 3 | MB |  |  |
| A69552 |  | Installation of Attenuators | 10d | 2019-07-28 | 2019-08-06 | A69322 | 119d | 14d | Mechanical Crew [100 h] | 9.43 | MEP | 3 | MB |  |  |
| A69562 |  | Installation of HVAC Fans | 10d | 2019-07-28 | 2019-08-06 | A69322 | 119d | 14d | Mechanical Crew [100 h] | 9.43 | MEP | 3 | MB |  |  |
| A69582 |  | Pressurization Unit | 8d | 2019-07-28 | 2019-08-04 | A69322 | 121d | 16d | Mechanical Crew [80 h] | 7.54 | MEP | 3 | MB |  |  |
| A69592 |  | Dosing pot | 5d | 2019-07-28 | 2019-08-01 | A69322 | 124d | 19d | Mechanical Crew [50 h] | 4.71 | MEP | 3 | MB |  |  |
| A69612 |  | Air Handling Units Installation | 12d | 2019-07-28 | 2019-08-07 | A69322 | 117d | 12d | Mechanical Crew [120 h] | 11.32 | MEP | 3 | MB |  |  |
| A69452 |  | Valves and Accessories | 10d | 2019-07-31 | 2019-08-13 | A69432 | 103.5d | 0d | Mechanical Crew [100 h] | 9.43 | MEP | 3 | MB |  |  |
| A69572 |  | Air-Cooled Chillers | 15d | 2019-07-31 | 2019-08-18 | A69432 | 110d | 5d | Mechanical Crew [150 h] | 14.15 | MEP | 3 | MB |  |  |
| A69622 |  | Chilled Water Pump Installation | 12d | 2019-07-31 | 2019-08-14 | A69432 | 113d | 8d | Mechanical Crew [120 h] | 11.32 | MEP | 3 | MB |  |  |
| A69462 |  | Chilled Water Pipe Insulation and Cladding | 10d | 2019-08-13 | 2019-08-22 | A69432, A69452 | 103.5d | 0d | Mechanical Crew [100 h] | 9.43 | MEP | 3 | MB |  |  |
|  | 1.4.1.4.1.1.4.1.1.-2 | **HVAC_Final Fix** |  | 2019-08-22 | 2019-11-14 |  |  |  |  |  |  |  |  |  |  |
| A69602 |  | Equuipment Connection | 8d | 2019-08-22 | 2019-08-29 | A69622, A69612, A69572, A69562, A69552, A69522, A69532, A69542, A69592, A69582, A69462 | 105d | 65.5d | Mechanical Crew [80 h] | 7.54 | MEP | 3 | MB |  |  |
| A69442 |  | Air Outlets (Grills, Diffusers, Registers etc...) | 15d | 2019-10-31 | 2019-11-14 | A69422, A69322, A69332, A69602, 1F5-FNS-B02-370 | 39.5d | 30d | Mechanical Crew [150 h] | 14.15 | MEP | 3 | MB |  |  |
|  | 1.4.1.4.1.1.4.1.2 | **PLUMBING SYSTEM** |  | 2019-07-15 | 2019-11-09 |  |  |  |  |  |  |  |  |  |  |
|  | 1.4.1.4.1.1.4.1.2.1. | **1st Fix** |  | 2019-07-15 | 2019-08-07 |  |  |  |  |  |  |  |  |  |  |
| A69202 |  | Hanger and support Installation | 10d | 2019-07-15 | 2019-07-23 | RM220 | 99.5d | 0d | Plumbing Crew [100 h] | 9.43 | MEP | 3 | MB | 1566 | CON |
| A69242 |  | Drainage and Vent Pipe & Fittings | 20d | 2019-07-20 | 2019-08-06 | A69202 SS+5d | 134d | 1d | Plumbing Crew [200 h] | 18.86 | MEP | 3 | MB | 1573 | CON |
| A69212 |  | Domestic Water Pipe & Fittings | 20d | 2019-07-20 | 2019-08-07 | A69202 SS+6d | 99.5d | 0d | Plumbing Crew [200 h] | 18.86 | MEP | 3 | MB | 1570 | CON |
|  | 1.4.1.4.1.1.4.1.2.-1 | **2nd Fix** |  | 2019-08-07 | 2019-08-26 |  |  |  |  |  |  |  |  |  |  |
| A69222 |  | Domestic Water Valves | 12d | 2019-08-07 | 2019-08-22 | A69212 | 99.5d | 0d | Plumbing Crew [120 h] | 11.32 | MEP | 3 | MB | 1571 | CON |
| A69482 |  | Sewege Pumps Installation | 5d | 2019-08-07 | 2019-08-15 | A69242, A69212 | 133d | 88d | Plumbing Crew [50 h] | 4.71 | MEP | 3 | MB |  |  |
| A69232 |  | Leak Test | 4d | 2019-08-22 | 2019-08-26 | A69222 | 99.5d | 62d | Plumbing Crew [40 h] | 3.77 | MEP | 3 | MB | 1572 | CON |

| ID | WBS | Activity | Duration | Start | Finish | Predecessors | Total float | Free float | Resources | Cost | Discipline | AREA | LOCATION | MSP Activity ID | MEP-Phase |
| --- | --- | --- | --- | --- | --- | --- | --- | --- | --- | --- | --- | --- | --- | --- | --- |
|  | 1.4.1.4.1.1.4.1.2.-2 | **PLM_Final Fix** |  | 2019-11-07 | 2019-11-09 |  |  |  |  |  |  |  |  |  |  |
| A69472 |  | Water Heaters | 2d | 2019-11-07 | 2019-11-09 | A69232, A69242, A69212, 1F5-FNS-B02-380 | 45d | 0d | Plumbing Crew [20 h] | 1.89 | MEP | 3 | MB |  |  |
| A69492 |  | Floor Drain | 2d | 2019-11-07 | 2019-11-09 | A69472 SS | 45d | 0d | Plumbing Crew [20 h] | 1.89 | MEP | 3 | MB |  |  |
| A69502 |  | Wash Basin / Water Closet | 2d | 2019-11-07 | 2019-11-09 | A69492 SS | 45d | 0d | Plumbing Crew [20 h] | 1.89 | MEP | 3 | MB |  |  |
| A69512 |  | Eye Wash | 2d | 2019-11-07 | 2019-11-09 | A69502 SS, A69482 | 45d | 22.5d | Plumbing Crew [20 h] | 1.89 | MEP | 3 | MB |  |  |
|  | 1.4.1.4.1.1.4.1.3 | **ELECTRICAL / CONTROLS** |  | 2019-07-15 | 2019-11-16 |  |  |  |  |  |  |  |  |  |  |
|  | 1.4.1.4.1.1.4.1.3.1. | **1st Fix** |  | 2019-07-15 | 2019-08-17 |  |  |  |  |  |  |  |  |  |  |
| A69302 |  | Installation of Conduits and Boxes | 12d | 2019-07-15 | 2019-07-25 | RM220 | 37.5d | 0d | Electrical Crew [120 h] | 11.32 | MEP | 3 | MB | 1592 | CON |
| A69312 |  | Installation of Cable Tray, Ladder and Trunk | 20d | 2019-07-25 | 2019-08-17 | A69302 | 98d | 0d | Electrical Crew [200 h] | 18.86 | MEP | 3 | MB | 1593 | CON |
|  | 1.4.1.4.1.1.4.1.3.-1 | **2nd Fix** |  | 2019-07-25 | 2019-10-24 |  |  |  |  |  |  |  |  |  |  |
| A69272 |  | Grounding and Bonding Installation | 20d | 2019-07-25 | 2019-08-17 | A69302 | 37.5d | 0d | Electrical Crew [200 h] | 18.86 | MEP | 3 | MB | 1596 | CON |
| A69632 |  | Wire Pulling | 20d | 2019-08-17 | 2019-09-04 | A69272 | 37.5d | 0d | Electrical Crew [200 h] | 18.86 | MEP | 3 | MB |  |  |
| A69692 |  | Installation of Bus Duct System | 20d | 2019-08-17 | 2019-09-04 | A69312 | 98d | 59.5d | Electrical Crew [200 h] | 18.86 | MEP | 3 | MB |  |  |
| A69252 |  | Power Cable Laying | 25d | 2019-09-04 | 2019-09-29 | A69632, A69272 | 37.5d | 0d | Electrical Crew [250 h] | 23.58 | MEP | 3 | MB | 1600 | CON |
| A69262 |  | Continuity Test - Power Cables | 4d | 2019-09-29 | 2019-10-02 | A69252 | 69d | 30.5d | Electrical Crew [40 h] | 3.77 | MEP | 3 | MB | 1601 | CON |
| A69642 |  | Installation of Central Battery Equipment | 6d | 2019-09-29 | 2019-10-05 | A69252, A69632 | 67d | 28.5d | Electrical Crew [60 h] | 5.66 | MEP | 3 | MB |  |  |
| A69652 |  | Installation of Disconnect Switch | 8d | 2019-09-29 | 2019-10-07 | A69252, A69632 | 65d | 26.5d | Electrical Crew [80 h] | 7.54 | MEP | 3 | MB |  |  |
| A69672 |  | Installation of Switch Boards (MDB, EMDB) | 15d | 2019-09-29 | 2019-10-13 | A69252, A69632 | 37.5d | 0d | Electrical Crew [150 h] | 14.15 | MEP | 3 | MB |  |  |
| A69682 |  | Installation of Panel Boards | 15d | 2019-09-29 | 2019-10-13 | A69252, A69632 | 37.5d | 0d | Electrical Crew [150 h] | 14.15 | MEP | 3 | MB |  |  |
| A69702 |  | Installation of MCC | 15d | 2019-09-29 | 2019-10-13 | A69252, A69632 | 37.5d | 0d | Electrical Crew [150 h] | 14.15 | MEP | 3 | MB |  |  |
| A69712 |  | Installation of Lighting Control System | 12d | 2019-09-29 | 2019-10-10 | A69252, A69632 | 40.5d | 3d | Electrical Crew [120 h] | 11.32 | MEP | 3 | MB |  |  |
| A69662 |  | Installation of Wiring Devices and Outlets | 12d | 2019-10-13 | 2019-10-24 | A69632, A69702, A69682, A69672, A69712 | 37.5d | 0d | Electrical Crew [120 h] | 11.32 | MEP | 3 | MB |  |  |
|  | 1.4.1.4.1.1.4.1.3.-2 | **Elec._Final Fix** |  | 2019-10-13 | 2019-11-16 |  |  |  |  |  |  |  |  |  |  |
| A69722 |  | Panel Board Termination | 8d | 2019-10-13 | 2019-10-21 | A69672, A69682, A69702 | 56d | 17.5d | Electrical Crew [80 h] | 7.54 | MEP | 3 | MB |  |  |
| A69292 |  | Wiring devices Termination | 6d | 2019-10-31 | 2019-11-06 | A69642, A69652, A69692, A69712, A69662, A69262, 1F5-FNS-B02-370 | 38.5d | 0d | Electrical Crew [60 h] | 5.66 | MEP | 3 | MB | 1617 | CON |
| A69282 |  | Lighting Fixtures Installation and Termination | 10d | 2019-11-06 | 2019-11-16 | A69252, A69632, A69722, A69292, LOE-SUM3-370 FF | 38.5d | 24d | Electrical Crew [100 h] | 9.43 | MEP | 3 | MB | 1616 | CON |

| ID | WBS | Activity | Type | Duration | Start | Finish | Predecessors | Total float | Free float | Calendar | Resources | Cost | MSP Activity ID | Discipline | MEP-Phase | AREA | LOCATION |
| --- | --- | --- | --- | --- | --- | --- | --- | --- | --- | --- | --- | --- | --- | --- | --- | --- | --- |
|  | 1.4.1.4.1.1.4.1.4 | **FIRE FIGHTING SYSTEM** |  |  | 2019-07-15 | 2019-11-24 |  |  |  |  |  |  |  |  |  |  |  |
|  | 1.4.1.4.1.1.4.1.4.1. | **1st Fix** |  |  | 2019-07-15 | 2019-08-28 |  |  |  |  |  |  |  |  |  |  |  |
| A69382 |  | Fire Fighting Hangers & Supports |  | 15d | 2019-07-15 | 2019-07-28 | RM220 | 66.5d | 0d |  | Fire Fighting Crew [150 h] | 14.15 | 1622 | MEP | CON | 3 | MB |
| A69352 |  | Pipe Installation |  | 30d | 2019-07-29 | 2019-08-28 | A69382 | 66.5d | 0d |  | FIRE FIGHTING [721 h]; FF pipe [412 Limt] | 67.99 | 1625 | MEP | CON | 3 | MB |
|  | 1.4.1.4.1.1.4.1.4.-1 | **2nd Fix** |  |  | 2019-08-29 | 2019-09-28 |  |  |  |  |  |  |  |  |  |  |  |
| A69362 |  | Valve and Accessories Installation |  | 20d | 2019-08-29 | 2019-09-16 | A69352, A69382 | 66.5d | 0d |  | Fire Fighting Crew [200 h] | 18.86 | 1627 | MEP | CON | 3 | MB |
| A69372 |  | Leak Test |  | 10d | 2019-09-17 | 2019-09-28 | A69362 | 66.5d | 29d |  | Fire Fighting Crew [100 h] | 9.43 | 1631 | MEP | CON | 3 | MB |
|  | 1.4.1.4.1.1.4.1.4.-2 | **FF_Final Fix** |  |  | 2019-10-31 | 2019-11-24 |  |  |  |  |  |  |  |  |  |  |  |
| A69392 |  | Installation of Sprinklers |  | 15d | 2019-10-31 | 2019-11-14 | A69352, A69362, A69372, 1F5-FNS-B02-370 | 39.5d | 0d |  | Fire Fighting Crew [150 h] | 14.15 | 1633 | MEP | CON | 3 | MB |
| A69402 |  | Instalaltion of Fire Extinguisher |  | 10d | 2019-11-14 | 2019-11-24 | A69352, A69392, A69732 FF, LOE-SUM3-370 FF | 94.5d | 95d |  | Fire Fighting Crew [100 h] | 9.43 |  | MEP | CON | 3 | MB |
| A69732 |  | Installation of Fire hose Cabinet |  | 5d | 2019-11-14 | 2019-11-19 | A69352, A69392 | 99.5d | 5d |  | Fire Fighting Crew [50 h] | 4.71 |  | MEP |  | 3 | MB |
|  | 1 | **NORTH CONCOURSE MEZZ & TV LOUVER - ZONE 01 AND 02** |  |  | 2019-07-27 | 2019-12-22 |  |  |  |  |  |  |  |  |  |  |  |
| LOE-SUM3-380 |  | North . B02 - MEP Works; 1st & 2nd Fix | level of effort | 111.75d | 2019-07-27 | 2019-11-07 | RM230 | 24d | 0d | Saudi |  |  |  | MEP |  |  |  |
| LOE-SUM3-390 |  | North . B02 - MEP Works; Final fix | level of effort | 117.5d | 2019-09-03 | 2019-12-22 | LOE-SUM3-380, A73922 SS | 9.5d | 0d | Saudi |  |  |  | MEP |  |  |  |
|  | 4 | **B02 - CONCOURSE MEZZ & TV LOUVER - ZONE 01** |  |  | 2019-07-29 | 2019-12-22 |  |  |  |  |  |  |  |  |  |  |  |
|  | 1.4.1.4.1.1.4.1.1 | **HVAC SYSTEM** |  |  | 2019-07-29 | 2019-12-12 |  |  |  |  |  |  |  |  |  |  |  |
|  | 1.4.1.4.1.1.4.1.1.1. | **1st Fix** |  |  | 2019-07-29 | 2019-08-18 |  |  |  |  |  |  |  |  |  |  |  |
| A71502 |  | Hanger and support Installation - Duct |  | 6d | 2019-07-29 | 2019-08-03 | RM240 | 80.5d | 0d |  | Mechanical Crew [60 h] | 5.66 | 1546 | MEP | CON | 1 | MB |
| A71572 |  | Hanger and support Installation - CHW |  | 6d | 2019-07-29 | 2019-08-03 | A71502 SS | 80.5d | 0d |  | Mechanical Crew [60 h] | 5.66 |  | MEP |  | 1 | MB |
| A71482 |  | Duct Installation |  | 12d | 2019-07-30 | 2019-08-14 | A71502 SS+2d | 99d | 0d |  | Duct Installation [260 Sqmt]; HVAC [780 h] | 73.55 | 1549 | MEP | CON | 1 | MB |
| A71492 |  | Duct Insulation |  | 8d | 2019-08-03 | 2019-08-13 | A71482 SS+3d | 123d | 113.5d |  | Duct Insulation [263 Sqmt]; HVAC [190 h] | 17.92 | 1552 | MEP | CON | 1 | MB |
| A71592 |  | Chilled Water Piping Installation |  | 12d | 2019-08-03 | 2019-08-18 | A71572 | 80.5d | 0d |  | Mechanical Crew [120 h] | 11.32 |  | MEP |  | 1 | MB |
|  | 1.4.1.4.1.1.4.1.1.-1 | **2nd Fix** |  |  | 2019-08-14 | 2019-09-05 |  |  |  |  |  |  |  |  |  |  |  |
| A71582 |  | Installation of Duct Accessories (VD, FD, MSD etc....) |  | 12d | 2019-08-14 | 2019-08-25 | A71482 | 110d | 100.5d |  | Mechanical Crew [120 h] | 11.32 |  | MEP |  | 1 | MB |
| A71682 |  | CRAC Units Installation |  | 15d | 2019-08-14 | 2019-08-28 | A71482 | 99d | 9d |  | Mechanical Crew [150 h] | 14.15 |  | MEP |  | 1 | MB |
| A71692 |  | FCU Installation |  | 15d | 2019-08-14 | 2019-08-28 | A71482 | 99d | 9d |  | Mechanical Crew [150 h] | 14.15 |  | MEP |  | 1 | MB |
| A71702 |  | VRF DX Units Installation |  | 12d | 2019-08-14 | 2019-08-25 | A71482 | 102d | 12d |  | Mechanical Crew [120 h] | 11.32 |  | MEP |  | 1 | MB |
| A71712 |  | Installation of Attenuators |  | 10d | 2019-08-14 | 2019-08-24 | A71482 | 104d | 14d |  | Mechanical Crew [100 h] | 9.43 |  | MEP |  | 1 | MB |
| A71722 |  | Installation of HVAC Fans |  | 10d | 2019-08-14 | 2019-08-24 | A71482 | 104d | 14d |  | Mechanical Crew [100 h] | 9.43 |  | MEP |  | 1 | MB |
| A71742 |  | Pressurization Unit |  | 8d | 2019-08-14 | 2019-08-21 | A71482 | 106d | 16d |  | Mechanical Crew [80 h] | 7.54 |  | MEP |  | 1 | MB |
| A71752 |  | Dosing pot |  | 5d | 2019-08-14 | 2019-08-19 | A71482 | 109d | 19d |  | Mechanical Crew [50 h] | 4.71 |  | MEP |  | 1 | MB |
| A71772 |  | Air Handling Units Installation |  | 12d | 2019-08-14 | 2019-08-25 | A71482 | 102d | 12d |  | Mechanical Crew [120 h] | 11.32 |  | MEP |  | 1 | MB |
| A71612 |  | Valves and Accessories |  | 10d | 2019-08-18 | 2019-08-27 | A71592 | 80.5d | 0d |  | Mechanical Crew [100 h] | 9.43 |  | MEP |  | 1 | MB |
| A71732 |  | Air-Cooled Chillers |  | 15d | 2019-08-18 | 2019-09-01 | A71592 | 95d | 5d |  | Mechanical Crew [150 h] | 14.15 |  | MEP |  | 1 | MB |
| A71782 |  | Chilled Water Pump Installation |  | 12d | 2019-08-18 | 2019-08-28 | A71592 | 98d | 8d |  | Mechanical Crew [120 h] | 11.32 |  | MEP |  | 1 | MB |
| A71622 |  | Chilled Water Pipe Insulation and Cladding |  | 10d | 2019-08-27 | 2019-09-05 | A71592, A71612 | 80.5d | 0d |  | Mechanical Crew [100 h] | 9.43 |  | MEP |  | 1 | MB |

| ID | WBS | Activity | Duration | Start | Finish | Predecessors | Total float | Free float | Resources | Cost | Discipline | AREA | LOCATION | MSP Activity ID | MEP-Phase |
| --- | --- | --- | --- | --- | --- | --- | --- | --- | --- | --- | --- | --- | --- | --- | --- |
|  | 1.4.1.4.1.1.4.1.1.-2 | **HVAC_Final Fix** |  | 2019-09-05 | 2019-12-12 |  |  |  |  |  |  |  |  |  |  |
| A71762 |  | Equuipment Connection | 8d | 2019-09-05 | 2019-09-12 | A71782, A71772, A71732, A71722, A71712, A71682, A71692, A71702, A71752, A71742, A71622 | 90d | 80.5d | Mechanical Crew [80 h] | 7.54 | MEP | 1 | MB |  |  |
| A71602 |  | Air Outlets (Grills, Diffusers, Registers etc...) | 15d | 2019-11-28 | 2019-12-12 | A71582, A71482, A71492, A71762, 1F5-FNS-B02-630 | 9.5d | 0d | Mechanical Crew [150 h] | 14.15 | MEP | 1 | MB |  |  |
|  | 1.4.1.4.1.1.4.1.2 | **PLUMBING SYSTEM** |  | 2019-07-29 | 2019-11-30 |  |  |  |  |  |  |  |  |  |  |
|  | 1.4.1.4.1.1.4.1.2.1. | **1st Fix** |  | 2019-07-29 | 2019-08-25 |  |  |  |  |  |  |  |  |  |  |
| A71362 |  | Hanger and support Installation | 10d | 2019-07-29 | 2019-08-06 | RM240 | 76.5d | 0d | Plumbing Crew [100 h] | 9.43 | MEP | 1 | MB | 1566 | CON |
| A71402 |  | Drainage and Vent Pipe & Fittings | 20d | 2019-08-03 | 2019-08-24 | A71362 SS+5d | 119d | 1d | Plumbing Crew [200 h] | 18.86 | MEP | 1 | MB | 1573 | CON |
| A71372 |  | Domestic Water Pipe & Fittings | 20d | 2019-08-03 | 2019-08-25 | A71362 SS+6d | 76.5d | 0d | Plumbing Crew [200 h] | 18.86 | MEP | 1 | MB | 1570 | CON |
|  | 1.4.1.4.1.1.4.1.2.-1 | **2nd Fix** |  | 2019-08-25 | 2019-09-09 |  |  |  |  |  |  |  |  |  |  |
| A71382 |  | Domestic Water Valves | 12d | 2019-08-25 | 2019-09-05 | A71372 | 76.5d | 0d | Plumbing Crew [120 h] | 11.32 | MEP | 1 | MB | 1571 | CON |
| A71642 |  | Sewege Pumps Installation | 5d | 2019-08-25 | 2019-08-29 | A71402, A71372 | 118d | 95.5d | Plumbing Crew [50 h] | 4.71 | MEP | 1 | MB |  |  |
| A71392 |  | Leak Test | 4d | 2019-09-05 | 2019-09-09 | A71382 | 76.5d | 62d | Plumbing Crew [40 h] | 3.77 | MEP | 1 | MB | 1572 | CON |
|  | 1.4.1.4.1.1.4.1.2.-2 | **PLM_Final Fix** |  | 2019-11-28 | 2019-11-30 |  |  |  |  |  |  |  |  |  |  |
| A71632 |  | Water Heaters | 2d | 2019-11-28 | 2019-11-30 | A71392, A71402, A71372, 1F5-FNS-B02-630 | 22.5d | 0d | Plumbing Crew [20 h] | 1.89 | MEP | 1 | MB |  |  |
| A71652 |  | Floor Drain | 2d | 2019-11-28 | 2019-11-30 | A71632 SS | 22.5d | 0d | Plumbing Crew [20 h] | 1.89 | MEP | 1 | MB |  |  |
| A71662 |  | Wash Basin / Water Closet | 2d | 2019-11-28 | 2019-11-30 | A71652 SS | 22.5d | 0d | Plumbing Crew [20 h] | 1.89 | MEP | 1 | MB |  |  |
| A71672 |  | Eye Wash | 2d | 2019-11-28 | 2019-11-30 | A71662 SS, A71642 | 22.5d | 0d | Plumbing Crew [20 h] | 1.89 | MEP | 1 | MB |  |  |
|  | 1.4.1.4.1.1.4.1.3 | **ELECTRICAL / CONTROLS** |  | 2019-07-29 | 2019-12-08 |  |  |  |  |  |  |  |  |  |  |
|  | 1.4.1.4.1.1.4.1.3.1. | **1st Fix** |  | 2019-07-29 | 2019-08-31 |  |  |  |  |  |  |  |  |  |  |
| A71462 |  | Installation of Conduits and Boxes | 12d | 2019-07-29 | 2019-08-08 | RM240 | 14.5d | 0d | Electrical Crew [120 h] | 11.32 | MEP | 1 | MB | 1592 | CON |
| A71472 |  | Installation of Cable Tray, Ladder and Trunk | 20d | 2019-08-08 | 2019-08-31 | A71462 | 93d | 0d | Electrical Crew [200 h] | 18.86 | MEP | 1 | MB | 1593 | CON |
|  | 1.4.1.4.1.1.4.1.3.-1 | **2nd Fix** |  | 2019-08-08 | 2019-11-07 |  |  |  |  |  |  |  |  |  |  |
| A71432 |  | Grounding and Bonding Installation | 20d | 2019-08-08 | 2019-08-31 | A71462 | 14.5d | 0d | Electrical Crew [200 h] | 18.86 | MEP | 1 | MB | 1596 | CON |
| A71792 |  | Wire Pulling | 20d | 2019-08-31 | 2019-09-18 | A71432 | 14.5d | 0d | Electrical Crew [200 h] | 18.86 | MEP | 1 | MB |  |  |
| A71852 |  | Installation of Bus Duct System | 20d | 2019-08-31 | 2019-09-18 | A71472 | 93d | 68.5d | Electrical Crew [200 h] | 18.86 | MEP | 1 | MB |  |  |
| A71412 |  | Power Cable Laying | 25d | 2019-09-18 | 2019-10-13 | A71792, A71432 | 14.5d | 0d | Electrical Crew [250 h] | 23.58 | MEP | 1 | MB | 1600 | CON |
| A71422 |  | Continuity Test - Power Cables | 4d | 2019-10-13 | 2019-10-16 | A71412 | 64d | 39.5d | Electrical Crew [40 h] | 3.77 | MEP | 1 | MB | 1601 | CON |
| A71802 |  | Installation of Central Battery Equipment | 6d | 2019-10-13 | 2019-10-19 | A71412, A71792 | 62d | 37.5d | Electrical Crew [60 h] | 5.66 | MEP | 1 | MB |  |  |
| A71812 |  | Installation of Disconnect Switch | 8d | 2019-10-13 | 2019-10-21 | A71412, A71792 | 60d | 35.5d | Electrical Crew [80 h] | 7.54 | MEP | 1 | MB |  |  |
| A71832 |  | Installation of Switch Boards (MDB, EMDB) | 15d | 2019-10-13 | 2019-10-27 | A71412, A71792 | 14.5d | 0d | Electrical Crew [150 h] | 14.15 | MEP | 1 | MB |  |  |
| A71842 |  | Installation of Panel Boards | 15d | 2019-10-13 | 2019-10-27 | A71412, A71792 | 14.5d | 0d | Electrical Crew [150 h] | 14.15 | MEP | 1 | MB |  |  |
| A71862 |  | Installation of MCC | 15d | 2019-10-13 | 2019-10-27 | A71412, A71792 | 14.5d | 0d | Electrical Crew [150 h] | 14.15 | MEP | 1 | MB |  |  |
| A71872 |  | Installation of Lighting Control System | 12d | 2019-10-13 | 2019-10-24 | A71412, A71792 | 17.5d | 3d | Electrical Crew [120 h] | 11.32 | MEP | 1 | MB |  |  |
| A71822 |  | Installation of Wiring Devices and Outlets | 12d | 2019-10-27 | 2019-11-07 | A71792, A71862, A71842, A71832, A71872 | 14.5d | 0d | Electrical Crew [120 h] | 11.32 | MEP | 1 | MB |  |  |

| ID | WBS | Activity | Duration | Start | Finish | Predecessors | Total float | Free float | Resources | Cost | Discipline | AREA | LOCATION | MSP Activity ID | MEP-Phase |
| --- | --- | --- | --- | --- | --- | --- | --- | --- | --- | --- | --- | --- | --- | --- | --- |
|  | 1.4.1.4.1.1.4.1.3.-2 | **Elec._Final Fix** |  | 2019-10-27 | 2019-12-08 |  |  |  |  |  |  |  |  |  |  |
| A71882 |  | Panel Board Termination | 8d | 2019-10-27 | 2019-11-04 | A71832, A71842, A71862 | 51d | 26.5d | Electrical Crew [80 h] | 7.54 | MEP | 1 | MB |  |  |
| A71452 |  | Wiring devices Termination | 6d | 2019-11-23 | 2019-11-28 | A71802, A71812, A71852, A71872, A71822, A71422, 1F5-FNS-B02-630 FF | 24.5d | 0d | Electrical Crew [60 h] | 5.66 | MEP | 1 | MB | 1617 | CON |
| A71442 |  | Lighting Fixtures Installation and Termination | 10d | 2019-11-28 | 2019-12-08 | A71412, A71792, A71882, A71452, LOE-SUM3-390 FF | 24.5d | 10d | Electrical Crew [100 h] | 9.43 | MEP | 1 | MB | 1616 | CON |
|  | 1.4.1.4.1.1.4.1.4 | **FIRE FIGHTING SYSTEM** |  | 2019-07-29 | 2019-12-22 |  |  |  |  |  |  |  |  |  |  |
|  | 1.4.1.4.1.1.4.1.4.1. | **1st Fix** |  | 2019-07-29 | 2019-09-11 |  |  |  |  |  |  |  |  |  |  |
| A71542 |  | Fire Fighting Hangers & Supports | 15d | 2019-07-29 | 2019-08-14 | RM240 | 43.5d | 0d | Fire Fighting Crew [150 h] | 14.15 | MEP | 1 | MB | 1622 | CON |
| A71512 |  | Pipe Installation | 30d | 2019-08-15 | 2019-09-11 | A71542 | 43.5d | 0d | FF pipe [206 Limt]; FIRE FIGHTING [361 h] | 34.04 | MEP | 1 | MB | 1625 | CON |
|  | 1.4.1.4.1.1.4.1.4.-1 | **2nd Fix** |  | 2019-09-12 | 2019-10-12 |  |  |  |  |  |  |  |  |  |  |
| A71522 |  | Valve and Accessories Installation | 20d | 2019-09-12 | 2019-10-02 | A71512, A71542 | 43.5d | 0d | Fire Fighting Crew [200 h] | 18.86 | MEP | 1 | MB | 1627 | CON |
| A71532 |  | Leak Test | 10d | 2019-10-02 | 2019-10-12 | A71522 | 43.5d | 29d | Fire Fighting Crew [100 h] | 9.43 | MEP | 1 | MB | 1631 | CON |
|  | 1.4.1.4.1.1.4.1.4.-2 | **FF_Final Fix** |  | 2019-11-28 | 2019-12-22 |  |  |  |  |  |  |  |  |  |  |
| A71552 |  | Installation of Sprinklers | 15d | 2019-11-28 | 2019-12-12 | A71512, A71522, A71532, 1F5-FNS-B02-630 | -0.5d | 0d | Fire Fighting Crew [150 h] | 14.15 | MEP | 1 | MB | 1633 | CON |
| A71892 |  | Installation of Fire hose Cabinet | 7.5d | 2019-12-05 | 2019-12-12 | A71512, A71552 FF | -0.5d | 0d | Fire Fighting Crew [75 h] | 7.07 | MEP | 1 | MB |  |  |
| A71562 |  | Instalaltion of Fire Extinguisher | 10d | 2019-12-12 | 2019-12-22 | A71512, A71552 FF, A71892, LOE-SUM3-390 FF | -0.5d | 0d | Fire Fighting Crew [100 h] | 9.43 | MEP | 1 | MB |  | CON |
|  | 5 | **B02 - CONCOURSE MEZZ & TV LOUVER - ZONE 02** |  | 2019-07-27 | 2019-12-10 |  |  |  |  |  |  |  |  |  |  |
|  | 1.4.1.4.1.1.4.1.1 | **HVAC SYSTEM** |  | 2019-07-27 | 2019-11-26 |  |  |  |  |  |  |  |  |  |  |
|  | 1.4.1.4.1.1.4.1.1.1. | **1st Fix** |  | 2019-07-27 | 2019-08-15 |  |  |  |  |  |  |  |  |  |  |
| A73662 |  | Hanger and support Installation - Duct | 6d | 2019-07-27 | 2019-07-31 | RM230 | 92d | 0d | Mechanical Crew [60 h] | 5.66 | MEP | 2 | MB | 1546 | CON |
| A73732 |  | Hanger and support Installation - CHW | 6d | 2019-07-27 | 2019-07-31 | A73662 SS | 92d | 0d | Mechanical Crew [60 h] | 5.66 | MEP | 2 | MB |  |  |
| A73642 |  | Duct Installation | 12d | 2019-07-28 | 2019-08-08 | A73662 SS+2d | 101.5d | 0d | Duct Installation [260 Sqmt]; HVAC [780 h] | 73.55 | MEP | 2 | MB | 1549 | CON |
| A73652 |  | Duct Insulation | 8d | 2019-07-31 | 2019-08-07 | A73642 SS+3d | 125.5d | 98.5d | Duct Insulation [263 Sqmt]; HVAC [190 h] | 17.92 | MEP | 2 | MB | 1552 | CON |
| A73752 |  | Chilled Water Piping Installation | 12d | 2019-07-31 | 2019-08-15 | A73732 | 92d | 0d | Mechanical Crew [120 h] | 11.32 | MEP | 2 | MB |  |  |
|  | 1.4.1.4.1.1.4.1.1.-1 | **2nd Fix** |  | 2019-08-08 | 2019-09-03 |  |  |  |  |  |  |  |  |  |  |
| A73742 |  | Installation of Duct Accessories (VD, FD, MSD etc....) | 12d | 2019-08-08 | 2019-08-22 | A73642 | 112.5d | 85.5d | Mechanical Crew [120 h] | 11.32 | MEP | 2 | MB |  |  |
| A73842 |  | CRAC Units Installation | 15d | 2019-08-08 | 2019-08-26 | A73642 | 101.5d | 9d | Mechanical Crew [150 h] | 14.15 | MEP | 2 | MB |  |  |
| A73852 |  | FCU Installation | 15d | 2019-08-08 | 2019-08-26 | A73642 | 101.5d | 9d | Mechanical Crew [150 h] | 14.15 | MEP | 2 | MB |  |  |
| A73862 |  | VRF DX Units Installation | 12d | 2019-08-08 | 2019-08-22 | A73642 | 104.5d | 12d | Mechanical Crew [120 h] | 11.32 | MEP | 2 | MB |  |  |
| A73872 |  | Installation of Attenuators | 10d | 2019-08-08 | 2019-08-21 | A73642 | 106.5d | 14d | Mechanical Crew [100 h] | 9.43 | MEP | 2 | MB |  |  |
| A73882 |  | Installation of HVAC Fans | 10d | 2019-08-08 | 2019-08-21 | A73642 | 106.5d | 14d | Mechanical Crew [100 h] | 9.43 | MEP | 2 | MB |  |  |
| A73902 |  | Pressurization Unit | 8d | 2019-08-08 | 2019-08-19 | A73642 | 108.5d | 16d | Mechanical Crew [80 h] | 7.54 | MEP | 2 | MB |  |  |
| A73912 |  | Dosing pot | 5d | 2019-08-08 | 2019-08-17 | A73642 | 111.5d | 19d | Mechanical Crew [50 h] | 4.71 | MEP | 2 | MB |  |  |
| A73932 |  | Air Handling Units Installation | 12d | 2019-08-08 | 2019-08-22 | A73642 | 104.5d | 12d | Mechanical Crew [120 h] | 11.32 | MEP | 2 | MB |  |  |
| A73772 |  | Valves and Accessories | 10d | 2019-08-15 | 2019-08-25 | A73752 | 92d | 0d | Mechanical Crew [100 h] | 9.43 | MEP | 2 | MB |  |  |
| A73892 |  | Air-Cooled Chillers | 15d | 2019-08-15 | 2019-08-29 | A73752 | 97.5d | 5d | Mechanical Crew [150 h] | 14.15 | MEP | 2 | MB |  |  |
| A73942 |  | Chilled Water Pump Installation | 12d | 2019-08-15 | 2019-08-26 | A73752 | 100.5d | 8d | Mechanical Crew [120 h] | 11.32 | MEP | 2 | MB |  |  |
| A73782 |  | Chilled Water Pipe Insulation and Cladding | 10d | 2019-08-25 | 2019-09-03 | A73752, A73772 | 92d | 0d | Mechanical Crew [100 h] | 9.43 | MEP | 2 | MB |  |  |

| ID | WBS | Activity | Duration | Start | Finish | Predecessors | Total float | Free float | Resources | Cost | Discipline | AREA | LOCATION | MSP Activity ID | MEP-Phase |
| --- | --- | --- | --- | --- | --- | --- | --- | --- | --- | --- | --- | --- | --- | --- | --- |
|  | 1.4.1.4.1.1.4.1.1.-2 | **HVAC_Final Fix** |  | 2019-09-03 | 2019-11-26 |  |  |  |  |  |  |  |  |  |  |
| A73922 |  | Equuipment Connection | 8d | 2019-09-03 | 2019-09-10 | A73942, A73932, A73892, A73882, A73872, A73842, A73852, A73862, A73912, A73902, A73782 | 92.5d | 65.5d | Mechanical Crew [80 h] | 7.54 | MEP | 2 | MB |  |  |
| A73762 |  | Air Outlets (Grills, Diffusers, Registers etc...) | 15d | 2019-11-12 | 2019-11-26 | A73742, A73642, A73652, A73922, 1F5-FNS-B02-5.. | 27d | 17.5d | Mechanical Crew [150 h] | 14.15 | MEP | 2 | MB |  |  |
|  | 1.4.1.4.1.1.4.1.2 | **PLUMBING SYSTEM** |  | 2019-07-27 | 2019-11-20 |  |  |  |  |  |  |  |  |  |  |
|  | 1.4.1.4.1.1.4.1.2.1. | **1st Fix** |  | 2019-07-27 | 2019-08-22 |  |  |  |  |  |  |  |  |  |  |
| A73522 |  | Hanger and support Installation | 10d | 2019-07-27 | 2019-08-04 | RM230 | 88d | 0d | Plumbing Crew [100 h] | 9.43 | MEP | 2 | MB | 1566 | CON |
| A73562 |  | Drainage and Vent Pipe & Fittings | 20d | 2019-07-31 | 2019-08-21 | A73522 SS+5d | 121.5d | 1d | Plumbing Crew [200 h] | 18.86 | MEP | 2 | MB | 1573 | CON |
| A73532 |  | Domestic Water Pipe & Fittings | 20d | 2019-07-31 | 2019-08-22 | A73522 SS+6d | 88d | 0d | Plumbing Crew [200 h] | 18.86 | MEP | 2 | MB | 1570 | CON |
|  | 1.4.1.4.1.1.4.1.2.-1 | **2nd Fix** |  | 2019-08-22 | 2019-09-07 |  |  |  |  |  |  |  |  |  |  |
| A73542 |  | Domestic Water Valves | 12d | 2019-08-22 | 2019-09-03 | A73532 | 88d | 0d | Plumbing Crew [120 h] | 11.32 | MEP | 2 | MB | 1571 | CON |
| A73802 |  | Sewege Pumps Installation | 5d | 2019-08-22 | 2019-08-27 | A73562, A73532 | 120.5d | 88d | Plumbing Crew [50 h] | 4.71 | MEP | 2 | MB |  |  |
| A73552 |  | Leak Test | 4d | 2019-09-03 | 2019-09-07 | A73542 | 88d | 62d | Plumbing Crew [40 h] | 3.77 | MEP | 2 | MB | 1572 | CON |
|  | 1.4.1.4.1.1.4.1.2.-2 | **PLM_Final Fix** |  | 2019-11-19 | 2019-11-20 |  |  |  |  |  |  |  |  |  |  |
| A73792 |  | Water Heaters | 2d | 2019-11-19 | 2019-11-20 | A73552, A73562, A73532, 1F5-FNS-B02-510 | 32.5d | 0d | Plumbing Crew [20 h] | 1.89 | MEP | 2 | MB |  |  |
| A73812 |  | Floor Drain | 2d | 2019-11-19 | 2019-11-20 | A73792 SS | 32.5d | 0d | Plumbing Crew [20 h] | 1.89 | MEP | 2 | MB |  |  |
| A73822 |  | Wash Basin / Water Closet | 2d | 2019-11-19 | 2019-11-20 | A73812 SS | 32.5d | 0d | Plumbing Crew [20 h] | 1.89 | MEP | 2 | MB |  |  |
| A73832 |  | Eye Wash | 2d | 2019-11-19 | 2019-11-20 | A73822 SS, A73802 | 32.5d | 10d | Plumbing Crew [20 h] | 1.89 | MEP | 2 | MB |  |  |
|  | 1.4.1.4.1.1.4.1.3 | **ELECTRICAL / CONTROLS** |  | 2019-07-27 | 2019-11-27 |  |  |  |  |  |  |  |  |  |  |
|  | 1.4.1.4.1.1.4.1.3.1. | **1st Fix** |  | 2019-07-27 | 2019-08-28 |  |  |  |  |  |  |  |  |  |  |
| A73622 |  | Installation of Conduits and Boxes | 12d | 2019-07-27 | 2019-08-06 | RM230 | 26d | 0d | Electrical Crew [120 h] | 11.32 | MEP | 2 | MB | 1592 | CON |
| A73632 |  | Installation of Cable Tray, Ladder and Trunk | 20d | 2019-08-06 | 2019-08-28 | A73622 | 85.5d | 0d | Electrical Crew [200 h] | 18.86 | MEP | 2 | MB | 1593 | CON |
|  | 1.4.1.4.1.1.4.1.3.-1 | **2nd Fix** |  | 2019-08-06 | 2019-11-05 |  |  |  |  |  |  |  |  |  |  |
| A73592 |  | Grounding and Bonding Installation | 20d | 2019-08-06 | 2019-08-28 | A73622 | 26d | 0d | Electrical Crew [200 h] | 18.86 | MEP | 2 | MB | 1596 | CON |
| A73952 |  | Wire Pulling | 20d | 2019-08-28 | 2019-09-16 | A73592 | 26d | 0d | Electrical Crew [200 h] | 18.86 | MEP | 2 | MB |  |  |
| A74012 |  | Installation of Bus Duct System | 20d | 2019-08-28 | 2019-09-16 | A73632 | 85.5d | 59.5d | Electrical Crew [200 h] | 18.86 | MEP | 2 | MB |  |  |
| A73572 |  | Power Cable Laying | 25d | 2019-09-16 | 2019-10-10 | A73952, A73592 | 26d | 0d | Electrical Crew [250 h] | 23.58 | MEP | 2 | MB | 1600 | CON |
| A73582 |  | Continuity Test - Power Cables | 4d | 2019-10-10 | 2019-10-14 | A73572 | 56.5d | 30.5d | Electrical Crew [40 h] | 3.77 | MEP | 2 | MB | 1601 | CON |
| A73962 |  | Installation of Central Battery Equipment | 6d | 2019-10-10 | 2019-10-16 | A73572, A73952 | 54.5d | 28.5d | Electrical Crew [60 h] | 5.66 | MEP | 2 | MB |  |  |
| A73972 |  | Installation of Disconnect Switch | 8d | 2019-10-10 | 2019-10-19 | A73572, A73952 | 52.5d | 26.5d | Electrical Crew [80 h] | 7.54 | MEP | 2 | MB |  |  |
| A73992 |  | Installation of Switch Boards (MDB, EMDB) | 15d | 2019-10-10 | 2019-10-24 | A73572, A73952 | 26d | 0d | Electrical Crew [150 h] | 14.15 | MEP | 2 | MB |  |  |
| A74002 |  | Installation of Panel Boards | 15d | 2019-10-10 | 2019-10-24 | A73572, A73952 | 26d | 0d | Electrical Crew [150 h] | 14.15 | MEP | 2 | MB |  |  |
| A74022 |  | Installation of MCC | 15d | 2019-10-10 | 2019-10-24 | A73572, A73952 | 26d | 0d | Electrical Crew [150 h] | 14.15 | MEP | 2 | MB |  |  |
| A74032 |  | Installation of Lighting Control System | 12d | 2019-10-10 | 2019-10-22 | A73572, A73952 | 29d | 3d | Electrical Crew [120 h] | 11.32 | MEP | 2 | MB |  |  |
| A73982 |  | Installation of Wiring Devices and Outlets | 12d | 2019-10-24 | 2019-11-05 | A73952, A74022, A74002, A73992, A74032 | 26d | 0d | Electrical Crew [120 h] | 11.32 | MEP | 2 | MB |  |  |

| ID | WBS | Activity | Type | Duration | Start | Finish | Predecessors | Total float | Free float | Calendar | Resources | Cost | Discipline | AREA | LOCATION | MSP Activity ID | MEP-Phase |
| --- | --- | --- | --- | --- | --- | --- | --- | --- | --- | --- | --- | --- | --- | --- | --- | --- | --- |
|  | 1.4.1.4.1.1.4.1.3.-2 | **Elec._Final Fix** |  |  | 2019-10-24 | 2019-11-27 |  |  |  |  |  |  |  |  |  |  |  |
| A74042 |  | Panel Board Termination |  | 8d | 2019-10-24 | 2019-11-02 | A73992, A74002, A74022 | 43.5d | 17.5d |  | Electrical Crew [80 h] | 7.54 | MEP | 2 | MB |  |  |
| A73612 |  | Wiring devices Termination |  | 6d | 2019-11-12 | 2019-11-18 | A73962, A73972, A74012, A74032, A73982, A73582, 1F5-FNS-B02-5.. | 26d | 0d |  | Electrical Crew [60 h] | 5.66 | MEP | 2 | MB | 1617 | CON |
| A73602 |  | Lighting Fixtures Installation and Termination |  | 10d | 2019-11-18 | 2019-11-27 | A73572, A73952, A74042, A73612 | 26d | 11.5d |  | Electrical Crew [100 h] | 9.43 | MEP | 2 | MB | 1616 | CON |
|  | 1.4.1.4.1.1.4.1.4 | **FIRE FIGHTING SYSTEM** |  |  | 2019-07-27 | 2019-12-10 |  |  |  |  |  |  |  |  |  |  |  |
|  | 1.4.1.4.1.1.4.1.4.1. | **1st Fix** |  |  | 2019-07-27 | 2019-09-09 |  |  |  |  |  |  |  |  |  |  |  |
| A73702 |  | Fire Fighting Hangers & Supports |  | 15d | 2019-07-27 | 2019-08-08 | RM230 | 55d | 0d |  | Fire Fighting Crew [150 h] | 14.15 | MEP | 2 | MB | 1622 | CON |
| A73672 |  | Pipe Installation |  | 30d | 2019-08-13 | 2019-09-09 | A73702 | 55d | 0d |  | FIRE FIGHTING [361 h]; FF pipe [206 Limt] | 34.04 | MEP | 2 | MB | 1625 | CON |
|  | 1.4.1.4.1.1.4.1.4.-1 | **2nd Fix** |  |  | 2019-09-10 | 2019-10-09 |  |  |  |  |  |  |  |  |  |  |  |
| A73682 |  | Valve and Accessories Installation |  | 20d | 2019-09-10 | 2019-09-30 | A73672, A73702 | 55d | 0d |  | Fire Fighting Crew [200 h] | 18.86 | MEP | 2 | MB | 1627 | CON |
| A73692 |  | Leak Test |  | 10d | 2019-09-30 | 2019-10-09 | A73682 | 55d | 29d |  | Fire Fighting Crew [100 h] | 9.43 | MEP | 2 | MB | 1631 | CON |
|  | 1.4.1.4.1.1.4.1.4.-2 | **FF_Final Fix** |  |  | 2019-11-12 | 2019-12-10 |  |  |  |  |  |  |  |  |  |  |  |
| A73712 |  | Installation of Sprinklers |  | 15d | 2019-11-12 | 2019-11-26 | A73672, A73682, A73692, 1F5-FNS-B02-5.. | 27d | 0d |  | Fire Fighting Crew [150 h] | 14.15 | MEP | 2 | MB | 1633 | CON |
| A74052 |  | Installation of Fire hose Cabinet |  | 5d | 2019-11-26 | 2019-12-01 | A73672, A73712 | 30.75d | 0d |  | Fire Fighting Crew [50 h] | 4.71 | MEP | 2 | MB |  |  |
| A73722 |  | Instalaltion of Fire Extinguisher |  | 10d | 2019-12-01 | 2019-12-10 | A73672, A73712, A74052 | 30.75d | 20d |  | Fire Fighting Crew [100 h] | 9.43 | MEP | 2 | MB |  | CON |
|  | 1.4.312 | **G00 - GROUND** |  |  | 2019-05-18 | 2019-12-08 |  |  |  |  |  |  |  |  |  |  |  |
| LOE-SUM3-400 |  | B01 - MEP Works; 1st & 2nd Fix | level of effort | 201.75d | 2019-05-18 | 2019-11-21 | RM260 | 9d | 0d | Saudi |  |  | MEP |  |  |  |  |
| LOE-SUM3-410 |  | B01 - MEP Works; Final fix | level of effort | 162.5d | 2019-07-09 | 2019-12-08 | LOE-SUM3-400, A76082 SS | 14.5d | 0d | Saudi |  |  | MEP |  |  |  |  |
|  | 7 | **SOUTH GROUND -ZONE 4 AND 5** |  |  | 2019-05-18 | 2019-09-29 |  |  |  |  |  |  |  |  |  |  |  |
|  | 1 | **G00 - GROUND ZONE 04** |  |  | 2019-06-01 | 2019-09-29 |  |  |  |  |  |  |  |  |  |  |  |
|  | 1.4.1.4.1.1.4.1.1 | **HVAC SYSTEM** |  |  | 2019-06-01 | 2019-07-30 |  |  |  |  |  |  |  |  |  |  |  |
|  | 1.4.1.4.1.1.4.1.1.1. | **1st Fix** |  |  | 2019-06-01 | 2019-06-20 |  |  |  |  |  |  |  |  |  |  |  |
| A75822 |  | Hanger and support Installation - Duct |  | 6d | 2019-06-01 | 2019-06-09 | RM250 | 148.25d | 0d |  | Mechanical Crew [60 h] | 5.66 | MEP | 4 | MB | 1546 | CON |
| A75892 |  | Hanger and support Installation - CHW |  | 6d | 2019-06-01 | 2019-06-09 | A75822 SS | 148.25d | 0d |  | Mechanical Crew [60 h] | 5.66 | MEP | 4 | MB |  |  |
| A75802 |  | Duct Installation |  | 12d | 2019-06-02 | 2019-06-17 | A75822 SS+2d | 157.75d | 0d |  | Duct Installation [260 Sqmt]; HVAC [780 h] | 73.55 | MEP | 4 | MB | 1549 | CON |
| A75812 |  | Duct Insulation |  | 8d | 2019-06-09 | 2019-06-16 | A75802 SS+3d | 181.75d | 33d |  | Duct Insulation [263 Sqmt]; HVAC [190 h] | 17.92 | MEP | 4 | MB | 1552 | CON |
| A75912 |  | Chilled Water Piping Installation |  | 12d | 2019-06-09 | 2019-06-20 | A75892 | 148.25d | 0d |  | Mechanical Crew [120 h] | 11.32 | MEP | 4 | MB |  |  |

| ID | WBS | Activity | Duration | Start | Finish | Predecessors | Total float | Free float | Resources | Cost | Discipline | AREA | LOCATION | MSP Activity ID | MEP-Phase |
| --- | --- | --- | --- | --- | --- | --- | --- | --- | --- | --- | --- | --- | --- | --- | --- |
|  | 1.4.1.4.1.1.4.1.1.-1 | **2nd Fix** |  | 2019-06-17 | 2019-07-09 |  |  |  |  |  |  |  |  |  |  |
| A75902 |  | Installation of Duct Accessories (VD, FD, MSD etc....) | 12d | 2019-06-17 | 2019-06-27 | A75802 | 168.75d | 20d | Mechanical Crew [120 h] | 11.32 | MEP | 4 | MB |  |  |
| A76002 |  | CRAC Units Installation | 15d | 2019-06-17 | 2019-07-01 | A75802 | 157.75d | 9d | Mechanical Crew [150 h] | 14.15 | MEP | 4 | MB |  |  |
| A76012 |  | FCU Installation | 15d | 2019-06-17 | 2019-07-01 | A75802 | 157.75d | 9d | Mechanical Crew [150 h] | 14.15 | MEP | 4 | MB |  |  |
| A76022 |  | VRF DX Units Installation | 12d | 2019-06-17 | 2019-06-27 | A75802 | 160.75d | 12d | Mechanical Crew [120 h] | 11.32 | MEP | 4 | MB |  |  |
| A76032 |  | Installation of Attenuators | 10d | 2019-06-17 | 2019-06-26 | A75802 | 162.75d | 14d | Mechanical Crew [100 h] | 9.43 | MEP | 4 | MB |  |  |
| A76042 |  | Installation of HVAC Fans | 10d | 2019-06-17 | 2019-06-26 | A75802 | 162.75d | 14d | Mechanical Crew [100 h] | 9.43 | MEP | 4 | MB |  |  |
| A76062 |  | Pressurization Unit | 8d | 2019-06-17 | 2019-06-24 | A75802 | 164.75d | 16d | Mechanical Crew [80 h] | 7.54 | MEP | 4 | MB |  |  |
| A76072 |  | Dosing pot | 5d | 2019-06-17 | 2019-06-22 | A75802 | 167.75d | 19d | Mechanical Crew [50 h] | 4.71 | MEP | 4 | MB |  |  |
| A76092 |  | Air Handling Units Installation | 12d | 2019-06-17 | 2019-06-27 | A75802 | 160.75d | 12d | Mechanical Crew [120 h] | 11.32 | MEP | 4 | MB |  |  |
| A75932 |  | Valves and Accessories | 10d | 2019-06-20 | 2019-06-30 | A75912 | 148.25d | 0d | Mechanical Crew [100 h] | 9.43 | MEP | 4 | MB |  |  |
| A76052 |  | Air-Cooled Chillers | 15d | 2019-06-20 | 2019-07-04 | A75912 | 153.75d | 5d | Mechanical Crew [150 h] | 14.15 | MEP | 4 | MB |  |  |
| A76102 |  | Chilled Water Pump Installation | 12d | 2019-06-20 | 2019-07-01 | A75912 | 156.75d | 8d | Mechanical Crew [120 h] | 11.32 | MEP | 4 | MB |  |  |
| A75942 |  | Chilled Water Pipe Insulation and Cladding | 10d | 2019-06-30 | 2019-07-09 | A75912, A75932 | 148.25d | 0d | Mechanical Crew [100 h] | 9.43 | MEP | 4 | MB |  |  |
|  | 1.4.1.4.1.1.4.1.1.-2 | **HVAC_Final Fix** |  | 2019-07-09 | 2019-07-30 |  |  |  |  |  |  |  |  |  |  |
| A76082 |  | Equuipment Connection | 8d | 2019-07-09 | 2019-07-16 | A76102, A76092, A76052, A76042, A76032, A76002, A76012, A76022, A76072, A76062, A75942 | 148.75d | 0d | Mechanical Crew [80 h] | 7.54 | MEP | 4 | MB |  |  |
| A75922 |  | Air Outlets (Grills, Diffusers, Registers etc...) | 15d | 2019-07-16 | 2019-07-30 | A75902, A75802, A75812, A76082 | 148.75d | 139.25d | Mechanical Crew [150 h] | 14.15 | MEP | 4 | MB |  |  |
|  | 1.4.1.4.1.1.4.1.2 | **PLUMBING SYSTEM** |  | 2019-06-01 | 2019-07-15 |  |  |  |  |  |  |  |  |  |  |
|  | 1.4.1.4.1.1.4.1.2.1. | **1st Fix** |  | 2019-06-01 | 2019-06-27 |  |  |  |  |  |  |  |  |  |  |
| A75682 |  | Hanger and support Installation | 10d | 2019-06-01 | 2019-06-12 | RM250 | 144.25d | 0d | Plumbing Crew [100 h] | 9.43 | MEP | 4 | MB | 1566 | CON |
| A75722 |  | Drainage and Vent Pipe & Fittings | 20d | 2019-06-09 | 2019-06-26 | A75682 SS+5d | 177.75d | 1d | Plumbing Crew [200 h] | 18.86 | MEP | 4 | MB | 1573 | CON |
| A75692 |  | Domestic Water Pipe & Fittings | 20d | 2019-06-09 | 2019-06-27 | A75682 SS+6d | 144.25d | 0d | Plumbing Crew [200 h] | 18.86 | MEP | 4 | MB | 1570 | CON |
|  | 1.4.1.4.1.1.4.1.2.-1 | **2nd Fix** |  | 2019-06-27 | 2019-07-13 |  |  |  |  |  |  |  |  |  |  |
| A75702 |  | Domestic Water Valves | 12d | 2019-06-27 | 2019-07-09 | A75692 | 144.25d | 0d | Plumbing Crew [120 h] | 11.32 | MEP | 4 | MB | 1571 | CON |
| A75962 |  | Sewege Pumps Installation | 5d | 2019-06-27 | 2019-07-02 | A75722, A75692 | 176.75d | 11d | Plumbing Crew [50 h] | 4.71 | MEP | 4 | MB |  |  |
| A75712 |  | Leak Test | 4d | 2019-07-09 | 2019-07-13 | A75702 | 144.25d | 0d | Plumbing Crew [40 h] | 3.77 | MEP | 4 | MB | 1572 | CON |

| ID | WBS | Activity | Duration | Start | Finish | Predecessors | Total float | Free float | Resources | Cost | Discipline | AREA | LOCATION | MSP Activity ID | MEP-Phase |
| --- | --- | --- | --- | --- | --- | --- | --- | --- | --- | --- | --- | --- | --- | --- | --- |
|  | 1.4.1.4.1.1.4.1.2.-2 | **PLM_Final Fix** |  | 2019-07-13 | 2019-07-15 |  |  |  |  |  |  |  |  |  |  |
| A75952 |  | Water Heaters | 2d | 2019-07-13 | 2019-07-15 | A75712, A75722, A75692 | 165.75d | 0d | Plumbing Crew [20 h] | 1.89 | MEP | 4 | MB |  |  |
| A75972 |  | Floor Drain | 2d | 2019-07-13 | 2019-07-15 | A75952 SS | 165.75d | 0d | Plumbing Crew [20 h] | 1.89 | MEP | 4 | MB |  |  |
| A75982 |  | Wash Basin / Water Closet | 2d | 2019-07-13 | 2019-07-15 | A75972 SS | 165.75d | 0d | Plumbing Crew [20 h] | 1.89 | MEP | 4 | MB |  |  |
| A75992 |  | Eye Wash | 2d | 2019-07-13 | 2019-07-15 | A75982 SS, A75962 | 165.75d | 143.25d | Plumbing Crew [20 h] | 1.89 | MEP | 4 | MB |  |  |
|  | 1.4.1.4.1.1.4.1.3 | **ELECTRICAL / CONTROLS** |  | 2019-06-01 | 2019-09-29 |  |  |  |  |  |  |  |  |  |  |
|  | 1.4.1.4.1.1.4.1.3.1. | **1st Fix** |  | 2019-06-01 | 2019-07-03 |  |  |  |  |  |  |  |  |  |  |
| A75782 |  | Installation of Conduits and Boxes | 12d | 2019-06-01 | 2019-06-15 | RM250 | 82.25d | 0d | Electrical Crew [120 h] | 11.32 | MEP | 4 | MB | 1592 | CON |
| A75792 |  | Installation of Cable Tray, Ladder and Trunk | 20d | 2019-06-15 | 2019-07-03 | A75782 | 141.75d | 0d | Electrical Crew [200 h] | 18.86 | MEP | 4 | MB | 1593 | CON |
|  | 1.4.1.4.1.1.4.1.3.-1 | **2nd Fix** |  | 2019-06-15 | 2019-09-12 |  |  |  |  |  |  |  |  |  |  |
| A75752 |  | Grounding and Bonding Installation | 20d | 2019-06-15 | 2019-07-03 | A75782 | 82.25d | 0d | Electrical Crew [200 h] | 18.86 | MEP | 4 | MB | 1596 | CON |
| A76112 |  | Wire Pulling | 20d | 2019-07-03 | 2019-07-22 | A75752 | 82.25d | 0d | Electrical Crew [200 h] | 18.86 | MEP | 4 | MB |  |  |
| A76172 |  | Installation of Bus Duct System | 20d | 2019-07-03 | 2019-07-22 | A75792 | 141.75d | 52d | Electrical Crew [200 h] | 18.86 | MEP | 4 | MB |  |  |
| A75732 |  | Power Cable Laying | 25d | 2019-07-22 | 2019-08-18 | A76112, A75752 | 82.25d | 0d | Electrical Crew [250 h] | 23.58 | MEP | 4 | MB | 1600 | CON |
| A75742 |  | Continuity Test - Power Cables | 4d | 2019-08-18 | 2019-08-21 | A75732 | 112.75d | 23d | Electrical Crew [40 h] | 3.77 | MEP | 4 | MB | 1601 | CON |
| A76122 |  | Installation of Central Battery Equipment | 6d | 2019-08-18 | 2019-08-24 | A75732, A76112 | 110.75d | 21d | Electrical Crew [60 h] | 5.66 | MEP | 4 | MB |  |  |
| A76132 |  | Installation of Disconnect Switch | 8d | 2019-08-18 | 2019-08-25 | A75732, A76112 | 108.75d | 19d | Electrical Crew [80 h] | 7.54 | MEP | 4 | MB |  |  |
| A76152 |  | Installation of Switch Boards (MDB, EMDB) | 15d | 2019-08-18 | 2019-09-01 | A75732, A76112 | 82.25d | 0d | Electrical Crew [150 h] | 14.15 | MEP | 4 | MB |  |  |
| A76162 |  | Installation of Panel Boards | 15d | 2019-08-18 | 2019-09-01 | A75732, A76112 | 82.25d | 0d | Electrical Crew [150 h] | 14.15 | MEP | 4 | MB |  |  |
| A76182 |  | Installation of MCC | 15d | 2019-08-18 | 2019-09-01 | A75732, A76112 | 82.25d | 0d | Electrical Crew [150 h] | 14.15 | MEP | 4 | MB |  |  |
| A76192 |  | Installation of Lighting Control System | 12d | 2019-08-18 | 2019-08-29 | A75732, A76112 | 85.25d | 3d | Electrical Crew [120 h] | 11.32 | MEP | 4 | MB |  |  |
| A76142 |  | Installation of Wiring Devices and Outlets | 12d | 2019-09-01 | 2019-09-12 | A76112, A76182, A76162, A76152, A76192 | 82.25d | 0d | Electrical Crew [120 h] | 11.32 | MEP | 4 | MB |  |  |
|  | 1.4.1.4.1.1.4.1.3.-2 | **Elec._Final Fix** |  | 2019-09-01 | 2019-09-29 |  |  |  |  |  |  |  |  |  |  |
| A76202 |  | Panel Board Termination | 8d | 2019-09-01 | 2019-09-08 | A76152, A76162, A76182 | 99.75d | 10d | Electrical Crew [80 h] | 7.54 | MEP | 4 | MB |  |  |
| A75772 |  | Wiring devices Termination | 6d | 2019-09-12 | 2019-09-17 | A76122, A76132, A76172, A76192, A76142, A75742 | 89.75d | 0d | Electrical Crew [60 h] | 5.66 | MEP | 4 | MB | 1617 | CON |
| A75762 |  | Lighting Fixtures Installation and Termination | 10d | 2019-09-18 | 2019-09-29 | A75732, A76112, A76202, A75772 | 89.75d | 75.25d | Electrical Crew [100 h] | 9.43 | MEP | 4 | MB | 1616 | CON |

| ID | WBS | Activity | Duration | Start | Finish | Predecessors | Total float | Free float | Resources | Cost | MSP Activity ID | Discipline | MEP-Phase | AREA | LOCATION |
| --- | --- | --- | --- | --- | --- | --- | --- | --- | --- | --- | --- | --- | --- | --- | --- |
|  | 1.4.1.4.1.1.4.1.4 | **FIRE FIGHTING SYSTEM** |  | 2019-06-01 | 2019-09-12 |  |  |  |  |  |  |  |  |  |  |
|  | 1.4.1.4.1.1.4.1.4.1. | **1st Fix** |  | 2019-06-01 | 2019-07-15 |  |  |  |  |  |  |  |  |  |  |
| A75862 |  | Fire Fighting Hangers & Supports | 15d | 2019-06-01 | 2019-06-17 | RM250 | 111.25d | 0d | Fire Fighting Crew [150 h] | 14.15 | 1622 | MEP | CON | 4 | MB |
| A75832 |  | Pipe Installation | 30d | 2019-06-18 | 2019-07-15 | A75862 | 111.25d | 0d | FF pipe [206 Limt]; FIRE FIGHTING [361 h] | 34.04 | 1625 | MEP | CON | 4 | MB |
|  | 1.4.1.4.1.1.4.1.4.-1 | **2nd Fix** |  | 2019-07-16 | 2019-08-15 |  |  |  |  |  |  |  |  |  |  |
| A75842 |  | Valve and Accessories Installation | 20d | 2019-07-16 | 2019-08-03 | A75832, A75862 | 111.25d | 0d | Fire Fighting Crew [200 h] | 18.86 | 1627 | MEP | CON | 4 | MB |
| A75852 |  | Leak Test | 10d | 2019-08-04 | 2019-08-15 | A75842 | 111.25d | 0d | Fire Fighting Crew [100 h] | 9.43 | 1631 | MEP | CON | 4 | MB |
|  | 1.4.1.4.1.1.4.1.4.-2 | **FF_Final Fix** |  | 2019-08-17 | 2019-09-12 |  |  |  |  |  |  |  |  |  |  |
| A75872 |  | Installation of Sprinklers | 15d | 2019-08-17 | 2019-08-29 | A75832, A75842, A75852 | 119.75d | 0d | Fire Fighting Crew [150 h] | 14.15 | 1633 | MEP | CON | 4 | MB |
| A76212 |  | Installation of Fire hose Cabinet | 5d | 2019-08-31 | 2019-09-03 | A75832, A75872 | 169.75d | 0d | Fire Fighting Crew [50 h] | 4.71 |  | MEP |  | 4 | MB |
| A75882 |  | Instalaltion of Fire Extinguisher | 10d | 2019-09-04 | 2019-09-12 | A75832, A75872, A76212, A76212 FF | 169.75d | 170.25d | Fire Fighting Crew [100 h] | 9.43 |  | MEP | CON | 4 | MB |
|  | 2 | **G00 - GROUND ZONE 05** |  | 2019-05-18 | 2019-09-12 |  |  |  |  |  |  |  |  |  |  |
|  | 1.4.1.4.1.1.4.1.1 | **HVAC SYSTEM** |  | 2019-05-18 | 2019-07-16 |  |  |  |  |  |  |  |  |  |  |
|  | 1.4.1.4.1.1.4.1.1.1. | **1st Fix** |  | 2019-05-18 | 2019-06-03 |  |  |  |  |  |  |  |  |  |  |
| A77982 |  | Hanger and support Installation - Duct | 6d | 2019-05-18 | 2019-05-22 | RM260 | 163.25d | 0d | Mechanical Crew [60 h] | 5.66 | 1546 | MEP | CON | 5 | MB |
| A78052 |  | Hanger and support Installation - CHW | 6d | 2019-05-18 | 2019-05-22 | A77982 SS | 163.25d | 0d | Mechanical Crew [60 h] | 5.66 |  | MEP |  | 5 | MB |
| A77962 |  | Duct Installation | 12d | 2019-05-19 | 2019-05-30 | A77982 SS+2d | 172.75d | 0d | Duct Installation [260 Sqmt]; HVAC [780 h] | 73.55 | 1549 | MEP | CON | 5 | MB |
| A77972 |  | Duct Insulation | 8d | 2019-05-22 | 2019-05-29 | A77962 SS+3d | 196.75d | 33d | Duct Insulation [263 Sqmt]; HVAC [190 h] | 17.92 | 1552 | MEP | CON | 5 | MB |
| A78072 |  | Chilled Water Piping Installation | 12d | 2019-05-22 | 2019-06-03 | A78052 | 163.25d | 0d | Mechanical Crew [120 h] | 11.32 |  | MEP |  | 5 | MB |
|  | 1.4.1.4.1.1.4.1.1.-1 | **2nd Fix** |  | 2019-05-30 | 2019-06-25 |  |  |  |  |  |  |  |  |  |  |
| A78062 |  | Installation of Duct Accessories (VD, FD, MSD etc....) | 12d | 2019-05-30 | 2019-06-13 | A77962 | 183.75d | 20d | Mechanical Crew [120 h] | 11.32 |  | MEP |  | 5 | MB |
| A78162 |  | CRAC Units Installation | 15d | 2019-05-30 | 2019-06-17 | A77962 | 172.75d | 9d | Mechanical Crew [150 h] | 14.15 |  | MEP |  | 5 | MB |
| A78172 |  | FCU Installation | 15d | 2019-05-30 | 2019-06-17 | A77962 | 172.75d | 9d | Mechanical Crew [150 h] | 14.15 |  | MEP |  | 5 | MB |
| A78182 |  | VRF DX Units Installation | 12d | 2019-05-30 | 2019-06-13 | A77962 | 175.75d | 12d | Mechanical Crew [120 h] | 11.32 |  | MEP |  | 5 | MB |
| A78192 |  | Installation of Attenuators | 10d | 2019-05-30 | 2019-06-12 | A77962 | 177.75d | 14d | Mechanical Crew [100 h] | 9.43 |  | MEP |  | 5 | MB |
| A78202 |  | Installation of HVAC Fans | 10d | 2019-05-30 | 2019-06-12 | A77962 | 177.75d | 14d | Mechanical Crew [100 h] | 9.43 |  | MEP |  | 5 | MB |
| A78222 |  | Pressurization Unit | 8d | 2019-05-30 | 2019-06-10 | A77962 | 179.75d | 16d | Mechanical Crew [80 h] | 7.54 |  | MEP |  | 5 | MB |
| A78232 |  | Dosing pot | 5d | 2019-05-30 | 2019-06-08 | A77962 | 182.75d | 19d | Mechanical Crew [50 h] | 4.71 |  | MEP |  | 5 | MB |
| A78252 |  | Air Handling Units Installation | 12d | 2019-05-30 | 2019-06-13 | A77962 | 175.75d | 12d | Mechanical Crew [120 h] | 11.32 |  | MEP |  | 5 | MB |
| A78092 |  | Valves and Accessories | 10d | 2019-06-03 | 2019-06-16 | A78072 | 163.25d | 0d | Mechanical Crew [100 h] | 9.43 |  | MEP |  | 5 | MB |
| A78212 |  | Air-Cooled Chillers | 15d | 2019-06-03 | 2019-06-20 | A78072 | 168.75d | 5d | Mechanical Crew [150 h] | 14.15 |  | MEP |  | 5 | MB |
| A78262 |  | Chilled Water Pump Installation | 12d | 2019-06-03 | 2019-06-17 | A78072 | 171.75d | 8d | Mechanical Crew [120 h] | 11.32 |  | MEP |  | 5 | MB |
| A78102 |  | Chilled Water Pipe Insulation and Cladding | 10d | 2019-06-16 | 2019-06-25 | A78072, A78092 | 163.25d | 0d | Mechanical Crew [100 h] | 9.43 |  | MEP |  | 5 | MB |

| ID | WBS | Activity | Duration | Start | Finish | Predecessors | Total float | Free float | Resources | Cost | Discipline | AREA | LOCATION | MSP Activity ID | MEP-Phase |
| --- | --- | --- | --- | --- | --- | --- | --- | --- | --- | --- | --- | --- | --- | --- | --- |
|  | 1.4.1.4.1.1.4.1.1.-2 | **HVAC_Final Fix** |  | 2019-06-25 | 2019-07-16 |  |  |  |  |  |  |  |  |  |  |
| A78242 |  | Equuipment Connection | 8d | 2019-06-25 | 2019-07-02 | A78262, A78252, A78212, A78202, A78192, A78162, A78172, A78182, A78232, A78222, A78102 | 163.75d | 0d | Mechanical Crew [80 h] | 7.54 | MEP | 5 | MB |  |  |
| A78082 |  | Air Outlets (Grills, Diffusers, Registers etc...) | 15d | 2019-07-02 | 2019-07-16 | A78062, A77962, A77972, A78242 | 163.75d | 154.25d | Mechanical Crew [150 h] | 14.15 | MEP | 5 | MB |  |  |
|  | 1.4.1.4.1.1.4.1.2 | **PLUMBING SYSTEM** |  | 2019-05-18 | 2019-07-01 |  |  |  |  |  |  |  |  |  |  |
|  | 1.4.1.4.1.1.4.1.2.1. | **1st Fix** |  | 2019-05-18 | 2019-06-13 |  |  |  |  |  |  |  |  |  |  |
| A77842 |  | Hanger and support Installation | 10d | 2019-05-18 | 2019-05-26 | RM260 | 159.25d | 0d | Plumbing Crew [100 h] | 9.43 | MEP | 5 | MB | 1566 | CON |
| A77882 |  | Drainage and Vent Pipe & Fittings | 20d | 2019-05-22 | 2019-06-12 | A77842 SS+5d | 192.75d | 1d | Plumbing Crew [200 h] | 18.86 | MEP | 5 | MB | 1573 | CON |
| A77852 |  | Domestic Water Pipe & Fittings | 20d | 2019-05-22 | 2019-06-13 | A77842 SS+6d | 159.25d | 0d | Plumbing Crew [200 h] | 18.86 | MEP | 5 | MB | 1570 | CON |
|  | 1.4.1.4.1.1.4.1.2.-1 | **2nd Fix** |  | 2019-06-13 | 2019-06-29 |  |  |  |  |  |  |  |  |  |  |
| A77862 |  | Domestic Water Valves | 12d | 2019-06-13 | 2019-06-25 | A77852 | 159.25d | 0d | Plumbing Crew [120 h] | 11.32 | MEP | 5 | MB | 1571 | CON |
| A78122 |  | Sewege Pumps Installation | 5d | 2019-06-13 | 2019-06-18 | A77882, A77852 | 191.75d | 11d | Plumbing Crew [50 h] | 4.71 | MEP | 5 | MB |  |  |
| A77872 |  | Leak Test | 4d | 2019-06-25 | 2019-06-29 | A77862 | 159.25d | 0d | Plumbing Crew [40 h] | 3.77 | MEP | 5 | MB | 1572 | CON |
|  | 1.4.1.4.1.1.4.1.2.-2 | **PLM_Final Fix** |  | 2019-06-29 | 2019-07-01 |  |  |  |  |  |  |  |  |  |  |
| A78112 |  | Water Heaters | 2d | 2019-06-29 | 2019-07-01 | A77872, A77882, A77852 | 180.75d | 0d | Plumbing Crew [20 h] | 1.89 | MEP | 5 | MB |  |  |
| A78132 |  | Floor Drain | 2d | 2019-06-29 | 2019-07-01 | A78112 SS | 180.75d | 0d | Plumbing Crew [20 h] | 1.89 | MEP | 5 | MB |  |  |
| A78142 |  | Wash Basin / Water Closet | 2d | 2019-06-29 | 2019-07-01 | A78132 SS | 180.75d | 0d | Plumbing Crew [20 h] | 1.89 | MEP | 5 | MB |  |  |
| A78152 |  | Eye Wash | 2d | 2019-06-29 | 2019-07-01 | A78142 SS, A78122 | 180.75d | 158.25d | Plumbing Crew [20 h] | 1.89 | MEP | 5 | MB |  |  |
|  | 1.4.1.4.1.1.4.1.3 | **ELECTRICAL / CONTROLS** |  | 2019-05-18 | 2019-09-12 |  |  |  |  |  |  |  |  |  |  |
|  | 1.4.1.4.1.1.4.1.3.1. | **1st Fix** |  | 2019-05-18 | 2019-06-19 |  |  |  |  |  |  |  |  |  |  |
| A77942 |  | Installation of Conduits and Boxes | 12d | 2019-05-18 | 2019-05-28 | RM260 | 97.25d | 0d | Electrical Crew [120 h] | 11.32 | MEP | 5 | MB | 1592 | CON |
| A77952 |  | Installation of Cable Tray, Ladder and Trunk | 20d | 2019-05-28 | 2019-06-19 | A77942 | 156.75d | 0d | Electrical Crew [200 h] | 18.86 | MEP | 5 | MB | 1593 | CON |
|  | 1.4.1.4.1.1.4.1.3.-1 | **2nd Fix** |  | 2019-05-28 | 2019-08-29 |  |  |  |  |  |  |  |  |  |  |
| A77912 |  | Grounding and Bonding Installation | 20d | 2019-05-28 | 2019-06-19 | A77942 | 97.25d | 0d | Electrical Crew [200 h] | 18.86 | MEP | 5 | MB | 1596 | CON |
| A78272 |  | Wire Pulling | 20d | 2019-06-19 | 2019-07-08 | A77912 | 97.25d | 0d | Electrical Crew [200 h] | 18.86 | MEP | 5 | MB |  |  |
| A78332 |  | Installation of Bus Duct System | 20d | 2019-06-19 | 2019-07-08 | A77952 | 156.75d | 52d | Electrical Crew [200 h] | 18.86 | MEP | 5 | MB |  |  |
| A77892 |  | Power Cable Laying | 25d | 2019-07-08 | 2019-07-31 | A78272, A77912 | 97.25d | 0d | Electrical Crew [250 h] | 23.58 | MEP | 5 | MB | 1600 | CON |
| A77902 |  | Continuity Test - Power Cables | 4d | 2019-07-31 | 2019-08-04 | A77892 | 127.75d | 23d | Electrical Crew [40 h] | 3.77 | MEP | 5 | MB | 1601 | CON |
| A78282 |  | Installation of Central Battery Equipment | 6d | 2019-07-31 | 2019-08-06 | A77892, A78272 | 125.75d | 21d | Electrical Crew [60 h] | 5.66 | MEP | 5 | MB |  |  |
| A78292 |  | Installation of Disconnect Switch | 8d | 2019-07-31 | 2019-08-07 | A77892, A78272 | 123.75d | 19d | Electrical Crew [80 h] | 7.54 | MEP | 5 | MB |  |  |
| A78312 |  | Installation of Switch Boards (MDB, EMDB) | 15d | 2019-07-31 | 2019-08-18 | A77892, A78272 | 97.25d | 0d | Electrical Crew [150 h] | 14.15 | MEP | 5 | MB |  |  |
| A78322 |  | Installation of Panel Boards | 15d | 2019-07-31 | 2019-08-18 | A77892, A78272 | 97.25d | 0d | Electrical Crew [150 h] | 14.15 | MEP | 5 | MB |  |  |
| A78342 |  | Installation of MCC | 15d | 2019-07-31 | 2019-08-18 | A77892, A78272 | 97.25d | 0d | Electrical Crew [150 h] | 14.15 | MEP | 5 | MB |  |  |
| A78352 |  | Installation of Lighting Control System | 12d | 2019-07-31 | 2019-08-15 | A77892, A78272 | 100.25d | 3d | Electrical Crew [120 h] | 11.32 | MEP | 5 | MB |  |  |
| A78302 |  | Installation of Wiring Devices and Outlets | 12d | 2019-08-18 | 2019-08-29 | A78272, A78342, A78322, A78312, A78352 | 97.25d | 0d | Electrical Crew [120 h] | 11.32 | MEP | 5 | MB |  |  |

| ID | WBS | Activity | Duration | Start | Finish | Predecessors | Total float | Free float | Resources | Cost | Discipline | AREA | LOCATION | MSP Activity ID | MEP-Phase |
| --- | --- | --- | --- | --- | --- | --- | --- | --- | --- | --- | --- | --- | --- | --- | --- |
|  | 1.4.1.4.1.1.4.1.3.-2 | **Elec._Final Fix** |  | 2019-08-18 | 2019-09-12 |  |  |  |  |  |  |  |  |  |  |
| A78362 |  | Panel Board Termination | 8d | 2019-08-18 | 2019-08-25 | A78312, A78322, A78342 | 114.75d | 10d | Electrical Crew [80 h] | 7.54 | MEP | 5 | MB |  |  |
| A77932 |  | Wiring devices Termination | 6d | 2019-08-29 | 2019-09-03 | A78282, A78292, A78332, A78352, A78302, A77902 | 104.75d | 0d | Electrical Crew [60 h] | 5.66 | MEP | 5 | MB | 1617 | CON |
| A77922 |  | Lighting Fixtures Installation and Termination | 10d | 2019-09-04 | 2019-09-12 | A77892, A78272, A78362, A77932 | 104.75d | 90.25d | Electrical Crew [100 h] | 9.43 | MEP | 5 | MB | 1616 | CON |
|  | 1.4.1.4.1.1.4.1.4 | **FIRE FIGHTING SYSTEM** |  | 2019-05-18 | 2019-08-25 |  |  |  |  |  |  |  |  |  |  |
|  | 1.4.1.4.1.1.4.1.4.1. | **1st Fix** |  | 2019-05-18 | 2019-07-01 |  |  |  |  |  |  |  |  |  |  |
| A78022 |  | Fire Fighting Hangers & Supports | 15d | 2019-05-18 | 2019-05-30 | RM260 | 126.25d | 0d | Fire Fighting Crew [150 h] | 14.15 | MEP | 5 | MB | 1622 | CON |
| A77992 |  | Pipe Installation | 30d | 2019-06-01 | 2019-07-01 | A78022 | 126.25d | 0d | FIRE FIGHTING [361 h]; FF pipe [206 Limt] | 34.04 | MEP | 5 | MB | 1625 | CON |
|  | 1.4.1.4.1.1.4.1.4.-1 | **2nd Fix** |  | 2019-07-02 | 2019-07-29 |  |  |  |  |  |  |  |  |  |  |
| A78002 |  | Valve and Accessories Installation | 20d | 2019-07-02 | 2019-07-20 | A77992, A78022 | 126.25d | 0d | Fire Fighting Crew [200 h] | 18.86 | MEP | 5 | MB | 1627 | CON |
| A78012 |  | Leak Test | 10d | 2019-07-21 | 2019-07-29 | A78002 | 126.25d | 0d | Fire Fighting Crew [100 h] | 9.43 | MEP | 5 | MB | 1631 | CON |
|  | 1.4.1.4.1.1.4.1.4.-2 | **FF_Final Fix** |  | 2019-07-30 | 2019-08-25 |  |  |  |  |  |  |  |  |  |  |
| A78032 |  | Installation of Sprinklers | 15d | 2019-07-30 | 2019-08-15 | A77992, A78002, A78012 | 134.75d | 0d | Fire Fighting Crew [150 h] | 14.15 | MEP | 5 | MB | 1633 | CON |
| A78042 |  | Instalaltion of Fire Extinguisher | 10d | 2019-08-17 | 2019-08-25 | A77992, A78032, A78372 FF | 189.75d | 190.25d | Fire Fighting Crew [100 h] | 9.43 | MEP | 5 | MB |  | CON |
| A78372 |  | Installation of Fire hose Cabinet | 5d | 2019-08-17 | 2019-08-20 | A77992, A78032 | 194.75d | 5d | Fire Fighting Crew [50 h] | 4.71 | MEP | 5 | MB |  |  |
|  | 6 | **CENTRAL GROUND - ZONE 03** |  | 2019-07-15 | 2019-11-09 |  |  |  |  |  |  |  |  |  |  |
|  | 3 | **G00 - GROUND ZONE 03** |  | 2019-07-15 | 2019-11-09 |  |  |  |  |  |  |  |  |  |  |
|  | 1.4.1.4.1.1.4.1.1 | **HVAC SYSTEM** |  | 2019-07-15 | 2019-09-12 |  |  |  |  |  |  |  |  |  |  |
|  | 1.4.1.4.1.1.4.1.1.1. | **1st Fix** |  | 2019-07-15 | 2019-07-31 |  |  |  |  |  |  |  |  |  |  |
| A80142 |  | Hanger and support Installation - Duct | 6d | 2019-07-15 | 2019-07-20 | RM270 | 103.5d | 0d | Mechanical Crew [60 h] | 5.66 | MEP | 3 | MB | 1546 | CON |
| A80212 |  | Hanger and support Installation - CHW | 6d | 2019-07-15 | 2019-07-20 | A80142 SS | 103.5d | 0d | Mechanical Crew [60 h] | 5.66 | MEP | 3 | MB |  |  |
| A80122 |  | Duct Installation | 12d | 2019-07-16 | 2019-07-28 | A80142 SS+2d | 114d | 0d | Duct Installation [520 Sqmt]; HVAC [1560 h] | 147.11 | MEP | 3 | MB | 1549 | CON |
| A80132 |  | Duct Insulation | 8d | 2019-07-20 | 2019-07-27 | A80122 SS+3d | 138d | 33d | Duct Insulation [535 Sqmt]; HVAC [380 h] | 35.83 | MEP | 3 | MB | 1552 | CON |
| A80232 |  | Chilled Water Piping Installation | 12d | 2019-07-20 | 2019-07-31 | A80212 | 103.5d | 0d | Mechanical Crew [120 h] | 11.32 | MEP | 3 | MB |  |  |

| ID | WBS | Activity | Duration | Start | Finish | Predecessors | Total float | Free float | Resources | Cost | Discipline | AREA | LOCATION | MSP Activity ID | MEP-Phase |
| --- | --- | --- | --- | --- | --- | --- | --- | --- | --- | --- | --- | --- | --- | --- | --- |
|  | 1.4.1.4.1.1.4.1.1.-1 | **2nd Fix** |  | 2019-07-28 | 2019-08-22 |  |  |  |  |  |  |  |  |  |  |
| A80222 |  | Installation of Duct Accessories (VD, FD, MSD etc....) | 12d | 2019-07-28 | 2019-08-07 | A80122 | 125d | 20d | Mechanical Crew [120 h] | 11.32 | MEP | 3 | MB |  |  |
| A80322 |  | CRAC Units Installation | 15d | 2019-07-28 | 2019-08-14 | A80122 | 114d | 9d | Mechanical Crew [150 h] | 14.15 | MEP | 3 | MB |  |  |
| A80332 |  | FCU Installation | 15d | 2019-07-28 | 2019-08-14 | A80122 | 114d | 9d | Mechanical Crew [150 h] | 14.15 | MEP | 3 | MB |  |  |
| A80342 |  | VRF DX Units Installation | 12d | 2019-07-28 | 2019-08-07 | A80122 | 117d | 12d | Mechanical Crew [120 h] | 11.32 | MEP | 3 | MB |  |  |
| A80352 |  | Installation of Attenuators | 10d | 2019-07-28 | 2019-08-06 | A80122 | 119d | 14d | Mechanical Crew [100 h] | 9.43 | MEP | 3 | MB |  |  |
| A80362 |  | Installation of HVAC Fans | 10d | 2019-07-28 | 2019-08-06 | A80122 | 119d | 14d | Mechanical Crew [100 h] | 9.43 | MEP | 3 | MB |  |  |
| A80382 |  | Pressurization Unit | 8d | 2019-07-28 | 2019-08-04 | A80122 | 121d | 16d | Mechanical Crew [80 h] | 7.54 | MEP | 3 | MB |  |  |
| A80392 |  | Dosing pot | 5d | 2019-07-28 | 2019-08-01 | A80122 | 124d | 19d | Mechanical Crew [50 h] | 4.71 | MEP | 3 | MB |  |  |
| A80412 |  | Air Handling Units Installation | 12d | 2019-07-28 | 2019-08-07 | A80122 | 117d | 12d | Mechanical Crew [120 h] | 11.32 | MEP | 3 | MB |  |  |
| A80252 |  | Valves and Accessories | 10d | 2019-07-31 | 2019-08-13 | A80232 | 103.5d | 0d | Mechanical Crew [100 h] | 9.43 | MEP | 3 | MB |  |  |
| A80372 |  | Air-Cooled Chillers | 15d | 2019-07-31 | 2019-08-18 | A80232 | 110d | 5d | Mechanical Crew [150 h] | 14.15 | MEP | 3 | MB |  |  |
| A80422 |  | Chilled Water Pump Installation | 12d | 2019-07-31 | 2019-08-14 | A80232 | 113d | 8d | Mechanical Crew [120 h] | 11.32 | MEP | 3 | MB |  |  |
| A80262 |  | Chilled Water Pipe Insulation and Cladding | 10d | 2019-08-13 | 2019-08-22 | A80232, A80252 | 103.5d | 0d | Mechanical Crew [100 h] | 9.43 | MEP | 3 | MB |  |  |
|  | 1.4.1.4.1.1.4.1.1.-2 | **HVAC_Final Fix** |  | 2019-08-22 | 2019-09-12 |  |  |  |  |  |  |  |  |  |  |
| A80402 |  | Equuipment Connection | 8d | 2019-08-22 | 2019-08-29 | A80422, A80412, A80372, A80362, A80352, A80322, A80332, A80342, A80392, A80382, A80262 | 105d | 0d | Mechanical Crew [80 h] | 7.54 | MEP | 3 | MB |  |  |
| A80242 |  | Air Outlets (Grills, Diffusers, Registers etc...) | 15d | 2019-08-29 | 2019-09-12 | A80222, A80122, A80132, A80402 | 105d | 95.5d | Mechanical Crew [150 h] | 14.15 | MEP | 3 | MB |  |  |
|  | 1.4.1.4.1.1.4.1.2 | **PLUMBING SYSTEM** |  | 2019-07-15 | 2019-08-28 |  |  |  |  |  |  |  |  |  |  |
|  | 1.4.1.4.1.1.4.1.2.1. | **1st Fix** |  | 2019-07-15 | 2019-08-07 |  |  |  |  |  |  |  |  |  |  |
| A80002 |  | Hanger and support Installation | 10d | 2019-07-15 | 2019-07-23 | RM270 | 99.5d | 0d | Plumbing Crew [100 h] | 9.43 | MEP | 3 | MB | 1566 | CON |
| A80042 |  | Drainage and Vent Pipe & Fittings | 20d | 2019-07-20 | 2019-08-06 | A80002 SS+5d | 134d | 1d | Plumbing Crew [200 h] | 18.86 | MEP | 3 | MB | 1573 | CON |
| A80012 |  | Domestic Water Pipe & Fittings | 20d | 2019-07-20 | 2019-08-07 | A80002 SS+6d | 99.5d | 0d | Plumbing Crew [200 h] | 18.86 | MEP | 3 | MB | 1570 | CON |
|  | 1.4.1.4.1.1.4.1.2.-1 | **2nd Fix** |  | 2019-08-07 | 2019-08-26 |  |  |  |  |  |  |  |  |  |  |
| A80022 |  | Domestic Water Valves | 12d | 2019-08-07 | 2019-08-22 | A80012 | 99.5d | 0d | Plumbing Crew [120 h] | 11.32 | MEP | 3 | MB | 1571 | CON |
| A80282 |  | Sewege Pumps Installation | 5d | 2019-08-07 | 2019-08-15 | A80042, A80012 | 133d | 11d | Plumbing Crew [50 h] | 4.71 | MEP | 3 | MB |  |  |
| A80032 |  | Leak Test | 4d | 2019-08-22 | 2019-08-26 | A80022 | 99.5d | 0d | Plumbing Crew [40 h] | 3.77 | MEP | 3 | MB | 1572 | CON |

| ID | WBS | Activity | Duration | Start | Finish | Predecessors | Total float | Free float | Resources | Cost | Discipline | AREA | LOCATION | MSP Activity ID | MEP-Phase |
| --- | --- | --- | --- | --- | --- | --- | --- | --- | --- | --- | --- | --- | --- | --- | --- |
|  | 1.4.1.4.1.1.4.1.2.-2 | **PLM_Final Fix** |  | 2019-08-26 | 2019-08-28 |  |  |  |  |  |  |  |  |  |  |
| A80272 |  | Water Heaters | 2d | 2019-08-26 | 2019-08-28 | A80032, A80042, A80012 | 122d | 0d | Plumbing Crew [20 h] | 1.89 | MEP | 3 | MB |  |  |
| A80292 |  | Floor Drain | 2d | 2019-08-26 | 2019-08-28 | A80272 SS | 122d | 0d | Plumbing Crew [20 h] | 1.89 | MEP | 3 | MB |  |  |
| A80302 |  | Wash Basin / Water Closet | 2d | 2019-08-26 | 2019-08-28 | A80292 SS | 122d | 0d | Plumbing Crew [20 h] | 1.89 | MEP | 3 | MB |  |  |
| A80312 |  | Eye Wash | 2d | 2019-08-26 | 2019-08-28 | A80302 SS, A80282 | 122d | 99.5d | Plumbing Crew [20 h] | 1.89 | MEP | 3 | MB |  |  |
|  | 1.4.1.4.1.1.4.1.3 | **ELECTRICAL / CONTROLS** |  | 2019-07-15 | 2019-11-09 |  |  |  |  |  |  |  |  |  |  |
|  | 1.4.1.4.1.1.4.1.3.1. | **1st Fix** |  | 2019-07-15 | 2019-08-17 |  |  |  |  |  |  |  |  |  |  |
| A80102 |  | Installation of Conduits and Boxes | 12d | 2019-07-15 | 2019-07-25 | RM270 | 37.5d | 0d | Electrical Crew [120 h] | 11.32 | MEP | 3 | MB | 1592 | CON |
| A80112 |  | Installation of Cable Tray, Ladder and Trunk | 20d | 2019-07-25 | 2019-08-17 | A80102 | 98d | 0d | Electrical Crew [200 h] | 18.86 | MEP | 3 | MB | 1593 | CON |
|  | 1.4.1.4.1.1.4.1.3.-1 | **2nd Fix** |  | 2019-07-25 | 2019-10-24 |  |  |  |  |  |  |  |  |  |  |
| A80072 |  | Grounding and Bonding Installation | 20d | 2019-07-25 | 2019-08-17 | A80102 | 37.5d | 0d | Electrical Crew [200 h] | 18.86 | MEP | 3 | MB | 1596 | CON |
| A80432 |  | Wire Pulling | 20d | 2019-08-17 | 2019-09-04 | A80072 | 37.5d | 0d | Electrical Crew [200 h] | 18.86 | MEP | 3 | MB |  |  |
| A80492 |  | Installation of Bus Duct System | 20d | 2019-08-17 | 2019-09-04 | A80112 | 98d | 52d | Electrical Crew [200 h] | 18.86 | MEP | 3 | MB |  |  |
| A80052 |  | Power Cable Laying | 25d | 2019-09-04 | 2019-09-29 | A80432, A80072 | 37.5d | 0d | Electrical Crew [250 h] | 23.58 | MEP | 3 | MB | 1600 | CON |
| A80062 |  | Continuity Test - Power Cables | 4d | 2019-09-29 | 2019-10-02 | A80052 | 69d | 23d | Electrical Crew [40 h] | 3.77 | MEP | 3 | MB | 1601 | CON |
| A80442 |  | Installation of Central Battery Equipment | 6d | 2019-09-29 | 2019-10-05 | A80052, A80432 | 67d | 21d | Electrical Crew [60 h] | 5.66 | MEP | 3 | MB |  |  |
| A80452 |  | Installation of Disconnect Switch | 8d | 2019-09-29 | 2019-10-07 | A80052, A80432 | 65d | 19d | Electrical Crew [80 h] | 7.54 | MEP | 3 | MB |  |  |
| A80472 |  | Installation of Switch Boards (MDB, EMDB) | 15d | 2019-09-29 | 2019-10-13 | A80052, A80432 | 37.5d | 0d | Electrical Crew [150 h] | 14.15 | MEP | 3 | MB |  |  |
| A80482 |  | Installation of Panel Boards | 15d | 2019-09-29 | 2019-10-13 | A80052, A80432 | 37.5d | 0d | Electrical Crew [150 h] | 14.15 | MEP | 3 | MB |  |  |
| A80502 |  | Installation of MCC | 15d | 2019-09-29 | 2019-10-13 | A80052, A80432 | 37.5d | 0d | Electrical Crew [150 h] | 14.15 | MEP | 3 | MB |  |  |
| A80512 |  | Installation of Lighting Control System | 12d | 2019-09-29 | 2019-10-10 | A80052, A80432 | 40.5d | 3d | Electrical Crew [120 h] | 11.32 | MEP | 3 | MB |  |  |
| A80462 |  | Installation of Wiring Devices and Outlets | 12d | 2019-10-13 | 2019-10-24 | A80432, A80502, A80482, A80472, A80512 | 37.5d | 0d | Electrical Crew [120 h] | 11.32 | MEP | 3 | MB |  |  |
|  | 1.4.1.4.1.1.4.1.3.-2 | **Elec._Final Fix** |  | 2019-10-13 | 2019-11-09 |  |  |  |  |  |  |  |  |  |  |
| A80522 |  | Panel Board Termination | 8d | 2019-10-13 | 2019-10-21 | A80472, A80482, A80502 | 56d | 10d | Electrical Crew [80 h] | 7.54 | MEP | 3 | MB |  |  |
| A80092 |  | Wiring devices Termination | 6d | 2019-10-24 | 2019-10-30 | A80442, A80452, A80492, A80512, A80462, A80062 | 46d | 0d | Electrical Crew [60 h] | 5.66 | MEP | 3 | MB | 1617 | CON |
| A80082 |  | Lighting Fixtures Installation and Termination | 10d | 2019-10-30 | 2019-11-09 | A80052, A80432, A80092, A80522 | 46d | 31.5d | Electrical Crew [100 h] | 9.43 | MEP | 3 | MB | 1616 | CON |

| ID | WBS | Activity | Duration | Start | Finish | Predecessors | Total float | Free float | Resources | Cost | MSP Activity ID | Discipline | MEP-Phase | AREA | LOCATION |
| --- | --- | --- | --- | --- | --- | --- | --- | --- | --- | --- | --- | --- | --- | --- | --- |
|  | 1.4.1.4.1.1.4.1.4 | **FIRE FIGHTING SYSTEM** |  | 2019-07-15 | 2019-10-21 |  |  |  |  |  |  |  |  |  |  |
|  | 1.4.1.4.1.1.4.1.4.1. | **1st Fix** |  | 2019-07-15 | 2019-08-28 |  |  |  |  |  |  |  |  |  |  |
| A80182 |  | Fire Fighting Hangers & Supports | 15d | 2019-07-15 | 2019-07-28 | RM270 | 66.5d | 0d | Fire Fighting Crew [150 h] | 14.15 | 1622 | MEP | CON | 3 | MB |
| A80152 |  | Pipe Installation | 30d | 2019-07-29 | 2019-08-28 | A80182 | 66.5d | 0d | FF pipe [412 Limt]; FIRE FIGHTING [721 h] | 67.99 | 1625 | MEP | CON | 3 | MB |
|  | 1.4.1.4.1.1.4.1.4.-1 | **2nd Fix** |  | 2019-08-29 | 2019-09-28 |  |  |  |  |  |  |  |  |  |  |
| A80162 |  | Valve and Accessories Installation | 20d | 2019-08-29 | 2019-09-16 | A80152, A80182 | 66.5d | 0d | Fire Fighting Crew [200 h] | 18.86 | 1627 | MEP | CON | 3 | MB |
| A80172 |  | Leak Test | 10d | 2019-09-17 | 2019-09-28 | A80162 | 66.5d | 0d | Fire Fighting Crew [100 h] | 9.43 | 1631 | MEP | CON | 3 | MB |
|  | 1.4.1.4.1.1.4.1.4.-2 | **FF_Final Fix** |  | 2019-09-28 | 2019-10-21 |  |  |  |  |  |  |  |  |  |  |
| A80192 |  | Installation of Sprinklers | 15d | 2019-09-28 | 2019-10-12 | A80152, A80162, A80172 | 76d | 0d | Fire Fighting Crew [150 h] | 14.15 | 1633 | MEP | CON | 3 | MB |
| A80202 |  | Instalaltion of Fire Extinguisher | 10d | 2019-10-12 | 2019-10-21 | A80152, A80192, A80532 FF | 131d | 131.5d | Fire Fighting Crew [100 h] | 9.43 |  | MEP | CON | 3 | MB |
| A80532 |  | Installation of Fire hose Cabinet | 5d | 2019-10-12 | 2019-10-16 | A80152, A80192 | 136d | 5d | Fire Fighting Crew [50 h] | 4.71 |  | MEP |  | 3 | MB |
|  | 1 | **NORTH GROUND - ZONE 01 AND 02** |  | 2019-07-27 | 2019-12-08 |  |  |  |  |  |  |  |  |  |  |
|  | 4 | **G00 - GROUND - ZONE 01** |  | 2019-08-15 | 2019-12-08 |  |  |  |  |  |  |  |  |  |  |
|  | 1.4.1.4.1.1.4.1.1 | **HVAC SYSTEM** |  | 2019-08-15 | 2019-10-12 |  |  |  |  |  |  |  |  |  |  |
|  | 1.4.1.4.1.1.4.1.1.1. | **1st Fix** |  | 2019-08-15 | 2019-09-01 |  |  |  |  |  |  |  |  |  |  |
| A82302 |  | Hanger and support Installation - Duct | 6d | 2019-08-15 | 2019-08-20 | RM290 | 65.5d | 0d | Mechanical Crew [60 h] | 5.66 | 1546 | MEP | CON | 1 | MB |
| A82372 |  | Hanger and support Installation - CHW | 6d | 2019-08-15 | 2019-08-20 | A82302 SS | 65.5d | 0d | Mechanical Crew [60 h] | 5.66 |  | MEP |  | 1 | MB |
| A82282 |  | Duct Installation | 12d | 2019-08-17 | 2019-08-28 | A82302 SS+2d | 84d | 0d | Duct Installation [260 Sqmt]; HVAC [780 h] | 73.55 | 1549 | MEP | CON | 1 | MB |
| A82292 |  | Duct Insulation | 8d | 2019-08-20 | 2019-08-27 | A82282 SS+3d | 108d | 33d | Duct Insulation [263 Sqmt]; HVAC [190 h] | 17.92 | 1552 | MEP | CON | 1 | MB |
| A82392 |  | Chilled Water Piping Installation | 12d | 2019-08-20 | 2019-09-01 | A82372 | 65.5d | 0d | Mechanical Crew [120 h] | 11.32 |  | MEP |  | 1 | MB |
|  | 1.4.1.4.1.1.4.1.1.-1 | **2nd Fix** |  | 2019-08-28 | 2019-09-19 |  |  |  |  |  |  |  |  |  |  |
| A82382 |  | Installation of Duct Accessories (VD, FD, MSD etc....) | 12d | 2019-08-28 | 2019-09-08 | A82282 | 95d | 20d | Mechanical Crew [120 h] | 11.32 |  | MEP |  | 1 | MB |
| A82482 |  | CRAC Units Installation | 15d | 2019-08-28 | 2019-09-11 | A82282 | 84d | 9d | Mechanical Crew [150 h] | 14.15 |  | MEP |  | 1 | MB |
| A82492 |  | FCU Installation | 15d | 2019-08-28 | 2019-09-11 | A82282 | 84d | 9d | Mechanical Crew [150 h] | 14.15 |  | MEP |  | 1 | MB |
| A82502 |  | VRF DX Units Installation | 12d | 2019-08-28 | 2019-09-08 | A82282 | 87d | 12d | Mechanical Crew [120 h] | 11.32 |  | MEP |  | 1 | MB |
| A82512 |  | Installation of Attenuators | 10d | 2019-08-28 | 2019-09-07 | A82282 | 89d | 14d | Mechanical Crew [100 h] | 9.43 |  | MEP |  | 1 | MB |
| A82522 |  | Installation of HVAC Fans | 10d | 2019-08-28 | 2019-09-07 | A82282 | 89d | 14d | Mechanical Crew [100 h] | 9.43 |  | MEP |  | 1 | MB |
| A82542 |  | Pressurization Unit | 8d | 2019-08-28 | 2019-09-04 | A82282 | 91d | 16d | Mechanical Crew [80 h] | 7.54 |  | MEP |  | 1 | MB |
| A82552 |  | Dosing pot | 5d | 2019-08-28 | 2019-09-02 | A82282 | 94d | 19d | Mechanical Crew [50 h] | 4.71 |  | MEP |  | 1 | MB |
| A82572 |  | Air Handling Units Installation | 12d | 2019-08-28 | 2019-09-08 | A82282 | 87d | 12d | Mechanical Crew [120 h] | 11.32 |  | MEP |  | 1 | MB |
| A82412 |  | Valves and Accessories | 10d | 2019-09-01 | 2019-09-10 | A82392 | 65.5d | 0d | Mechanical Crew [100 h] | 9.43 |  | MEP |  | 1 | MB |
| A82532 |  | Air-Cooled Chillers | 15d | 2019-09-01 | 2019-09-15 | A82392 | 80d | 5d | Mechanical Crew [150 h] | 14.15 |  | MEP |  | 1 | MB |
| A82582 |  | Chilled Water Pump Installation | 12d | 2019-09-01 | 2019-09-11 | A82392 | 83d | 8d | Mechanical Crew [120 h] | 11.32 |  | MEP |  | 1 | MB |
| A82422 |  | Chilled Water Pipe Insulation and Cladding | 10d | 2019-09-10 | 2019-09-19 | A82392, A82412 | 65.5d | 0d | Mechanical Crew [100 h] | 9.43 |  | MEP |  | 1 | MB |

| ID | WBS | Activity | Duration | Start | Finish | Predecessors | Total float | Free float | Resources | Cost | Discipline | AREA | LOCATION | MSP Activity ID | MEP-Phase |
| --- | --- | --- | --- | --- | --- | --- | --- | --- | --- | --- | --- | --- | --- | --- | --- |
|  | 1.4.1.4.1.1.4.1.1.-2 | **HVAC_Final Fix** |  | 2019-09-19 | 2019-10-12 |  |  |  |  |  |  |  |  |  |  |
| A82562 |  | Equuipment Connection | 8d | 2019-09-19 | 2019-09-28 | A82582, A82572, A82532, A82522, A82512, A82482, A82492, A82502, A82552, A82542, A82422 | 75d | 0d | Mechanical Crew [80 h] | 7.54 | MEP | 1 | MB |  |  |
| A82402 |  | Air Outlets (Grills, Diffusers, Registers etc...) | 15d | 2019-09-29 | 2019-10-12 | A82382, A82282, A82292, A82562 | 75d | 65.5d | Mechanical Crew [150 h] | 14.15 | MEP | 1 | MB |  |  |
|  | 1.4.1.4.1.1.4.1.2 | **PLUMBING SYSTEM** |  | 2019-08-15 | 2019-09-26 |  |  |  |  |  |  |  |  |  |  |
|  | 1.4.1.4.1.1.4.1.2.1. | **1st Fix** |  | 2019-08-15 | 2019-09-08 |  |  |  |  |  |  |  |  |  |  |
| A82162 |  | Hanger and support Installation | 10d | 2019-08-15 | 2019-08-24 | RM290 | 61.5d | 0d | Plumbing Crew [100 h] | 9.43 | MEP | 1 | MB | 1566 | CON |
| A82202 |  | Drainage and Vent Pipe & Fittings | 20d | 2019-08-20 | 2019-09-07 | A82162 SS+5d | 104d | 1d | Plumbing Crew [200 h] | 18.86 | MEP | 1 | MB | 1573 | CON |
| A82172 |  | Domestic Water Pipe & Fittings | 20d | 2019-08-20 | 2019-09-08 | A82162 SS+6d | 61.5d | 0d | Plumbing Crew [200 h] | 18.86 | MEP | 1 | MB | 1570 | CON |
|  | 1.4.1.4.1.1.4.1.2.-1 | **2nd Fix** |  | 2019-09-08 | 2019-09-24 |  |  |  |  |  |  |  |  |  |  |
| A82182 |  | Domestic Water Valves | 12d | 2019-09-08 | 2019-09-19 | A82172 | 61.5d | 0d | Plumbing Crew [120 h] | 11.32 | MEP | 1 | MB | 1571 | CON |
| A82442 |  | Sewege Pumps Installation | 5d | 2019-09-08 | 2019-09-12 | A82202, A82172 | 103d | 11d | Plumbing Crew [50 h] | 4.71 | MEP | 1 | MB |  |  |
| A82192 |  | Leak Test | 4d | 2019-09-19 | 2019-09-24 | A82182 | 61.5d | 0d | Plumbing Crew [40 h] | 3.77 | MEP | 1 | MB | 1572 | CON |
|  | 1.4.1.4.1.1.4.1.2.-2 | **PLM_Final Fix** |  | 2019-09-24 | 2019-09-26 |  |  |  |  |  |  |  |  |  |  |
| A82432 |  | Water Heaters | 2d | 2019-09-24 | 2019-09-26 | A82192, A82202, A82172 | 92d | 0d | Plumbing Crew [20 h] | 1.89 | MEP | 1 | MB |  |  |
| A82452 |  | Floor Drain | 2d | 2019-09-24 | 2019-09-26 | A82432 SS | 92d | 0d | Plumbing Crew [20 h] | 1.89 | MEP | 1 | MB |  |  |
| A82462 |  | Wash Basin / Water Closet | 2d | 2019-09-24 | 2019-09-26 | A82452 SS | 92d | 0d | Plumbing Crew [20 h] | 1.89 | MEP | 1 | MB |  |  |
| A82472 |  | Eye Wash | 2d | 2019-09-24 | 2019-09-26 | A82462 SS, A82442 | 92d | 69.5d | Plumbing Crew [20 h] | 1.89 | MEP | 1 | MB |  |  |
|  | 1.4.1.4.1.1.4.1.3 | **ELECTRICAL / CONTROLS** |  | 2019-08-15 | 2019-12-08 |  |  |  |  |  |  |  |  |  |  |
|  | 1.4.1.4.1.1.4.1.3.1. | **1st Fix** |  | 2019-08-15 | 2019-09-14 |  |  |  |  |  |  |  |  |  |  |
| A82262 |  | Installation of Conduits and Boxes | 12d | 2019-08-15 | 2019-08-26 | RM290 | -0.5d | 0d | Electrical Crew [120 h] | 11.32 | MEP | 1 | MB | 1592 | CON |
| A82272 |  | Installation of Cable Tray, Ladder and Trunk | 20d | 2019-08-26 | 2019-09-14 | A82262 | 66.5d | 0d | Electrical Crew [200 h] | 18.86 | MEP | 1 | MB | 1593 | CON |
|  | 1.4.1.4.1.1.4.1.3.-1 | **2nd Fix** |  | 2019-08-26 | 2019-11-21 |  |  |  |  |  |  |  |  |  |  |
| A82232 |  | Grounding and Bonding Installation | 20d | 2019-08-26 | 2019-09-14 | A82262 | -0.5d | 0d | Electrical Crew [200 h] | 18.86 | MEP | 1 | MB | 1596 | CON |
| A82592 |  | Wire Pulling | 20d | 2019-09-14 | 2019-10-03 | A82232 | -0.5d | 0d | Electrical Crew [200 h] | 18.86 | MEP | 1 | MB |  |  |
| A82652 |  | Installation of Bus Duct System | 20d | 2019-09-14 | 2019-10-03 | A82272 | 66.5d | 52d | Electrical Crew [200 h] | 18.86 | MEP | 1 | MB |  |  |
| A82212 |  | Power Cable Laying | 25d | 2019-10-03 | 2019-10-27 | A82592, A82232 | -0.5d | 0d | Electrical Crew [250 h] | 23.58 | MEP | 1 | MB | 1600 | CON |
| A82222 |  | Continuity Test - Power Cables | 4d | 2019-10-27 | 2019-10-30 | A82212 | 37.5d | 23d | Electrical Crew [40 h] | 3.77 | MEP | 1 | MB | 1601 | CON |
| A82602 |  | Installation of Central Battery Equipment | 6d | 2019-10-27 | 2019-11-02 | A82212, A82592 | 35.5d | 21d | Electrical Crew [60 h] | 5.66 | MEP | 1 | MB |  |  |
| A82612 |  | Installation of Disconnect Switch | 8d | 2019-10-27 | 2019-11-04 | A82212, A82592 | 33.5d | 19d | Electrical Crew [80 h] | 7.54 | MEP | 1 | MB |  |  |
| A82632 |  | Installation of Switch Boards (MDB, EMDB) | 15d | 2019-10-27 | 2019-11-10 | A82212, A82592 | -0.5d | 0d | Electrical Crew [150 h] | 14.15 | MEP | 1 | MB |  |  |
| A82642 |  | Installation of Panel Boards | 15d | 2019-10-27 | 2019-11-10 | A82212, A82592 | -0.5d | 0d | Electrical Crew [150 h] | 14.15 | MEP | 1 | MB |  |  |
| A82662 |  | Installation of MCC | 15d | 2019-10-27 | 2019-11-10 | A82212, A82592 | -0.5d | 0d | Electrical Crew [150 h] | 14.15 | MEP | 1 | MB |  |  |
| A82672 |  | Installation of Lighting Control System | 12d | 2019-10-27 | 2019-11-07 | A82212, A82592 | 2.5d | 3d | Electrical Crew [120 h] | 11.32 | MEP | 1 | MB |  |  |
| A82622 |  | Installation of Wiring Devices and Outlets | 12d | 2019-11-10 | 2019-11-21 | A82592, A82662, A82642, A82632, A82672 | -0.5d | 0d | Electrical Crew [120 h] | 11.32 | MEP | 1 | MB |  |  |

| ID | WBS | Activity | Duration | Start | Finish | Predecessors | Total float | Free float | Resources | Cost | Discipline | AREA | LOCATION | MSP Activity ID | MEP-Phase |
| --- | --- | --- | --- | --- | --- | --- | --- | --- | --- | --- | --- | --- | --- | --- | --- |
|  | 1.4.1.4.1.1.4.1.3.-2 | **Elec._Final Fix** |  | 2019-11-10 | 2019-12-08 |  |  |  |  |  |  |  |  |  |  |
| A82682 |  | Panel Board Termination | 8d | 2019-11-10 | 2019-11-18 | A82632, A82642, A82662 | 26d | 11.5d | Electrical Crew [80 h] | 7.54 | MEP | 1 | MB |  |  |
| A82252 |  | Wiring devices Termination | 7.5d | 2019-11-21 | 2019-11-28 | A82602, A82612, A82652, A82672, A82622, A82222 | 14.5d | 0d | Electrical Crew [75 h] | 7.07 | MEP | 1 | MB | 1617 | CON |
| A82242 |  | Lighting Fixtures Installation and Termination | 10d | 2019-11-28 | 2019-12-08 | A82212, A82592, A82682, A82252, LOE-SUM3-410 FF | 14.5d | 0d | Electrical Crew [100 h] | 9.43 | MEP | 1 | MB | 1616 | CON |
|  | 1.4.1.4.1.1.4.1.4 | **FIRE FIGHTING SYSTEM** |  | 2019-08-15 | 2019-11-18 |  |  |  |  |  |  |  |  |  |  |
|  | 1.4.1.4.1.1.4.1.4.1. | **1st Fix** |  | 2019-08-15 | 2019-09-28 |  |  |  |  |  |  |  |  |  |  |
| A82342 |  | Fire Fighting Hangers & Supports | 15d | 2019-08-15 | 2019-08-28 | RM290 | 28.5d | 0d | Fire Fighting Crew [150 h] | 14.15 | MEP | 1 | MB | 1622 | CON |
| A82312 |  | Pipe Installation | 30d | 2019-08-29 | 2019-09-28 | A82342 | 28.5d | 0d | FIRE FIGHTING [361 h]; FF pipe [206 Limt] | 34.04 | MEP | 1 | MB | 1625 | CON |
|  | 1.4.1.4.1.1.4.1.4.-1 | **2nd Fix** |  | 2019-09-28 | 2019-10-26 |  |  |  |  |  |  |  |  |  |  |
| A82322 |  | Valve and Accessories Installation | 20d | 2019-09-28 | 2019-10-16 | A82312, A82342 | 28.5d | 0d | Fire Fighting Crew [200 h] | 18.86 | MEP | 1 | MB | 1627 | CON |
| A82332 |  | Leak Test | 10d | 2019-10-16 | 2019-10-26 | A82322 | 28.5d | 0d | Fire Fighting Crew [100 h] | 9.43 | MEP | 1 | MB | 1631 | CON |
|  | 1.4.1.4.1.1.4.1.4.-2 | **FF_Final Fix** |  | 2019-10-26 | 2019-11-18 |  |  |  |  |  |  |  |  |  |  |
| A82352 |  | Installation of Sprinklers | 15d | 2019-10-26 | 2019-11-09 | A82312, A82322, A82332 | 41d | 0d | Fire Fighting Crew [150 h] | 14.15 | MEP | 1 | MB | 1633 | CON |
| A82362 |  | Instalaltion of Fire Extinguisher | 10d | 2019-11-09 | 2019-11-18 | A82312, A82352, A82692 FF | 101d | 101.5d | Fire Fighting Crew [100 h] | 9.43 | MEP | 1 | MB |  | CON |
| A82692 |  | Installation of Fire hose Cabinet | 5d | 2019-11-09 | 2019-11-13 | A82312, A82352 | 41d | 5d | Fire Fighting Crew [50 h] | 4.71 | MEP | 1 | MB |  |  |
|  | 5 | **G00 - GROUND - ZONE 02** |  | 2019-07-27 | 2019-11-20 |  |  |  |  |  |  |  |  |  |  |
|  | 1.4.1.4.1.1.4.1.1 | **HVAC SYSTEM** |  | 2019-07-27 | 2019-09-25 |  |  |  |  |  |  |  |  |  |  |
|  | 1.4.1.4.1.1.4.1.1.1. | **1st Fix** |  | 2019-07-27 | 2019-08-15 |  |  |  |  |  |  |  |  |  |  |
| A84462 |  | Hanger and support Installation - Duct | 6d | 2019-07-27 | 2019-07-31 | RM280 | 92d | 0d | Mechanical Crew [60 h] | 5.66 | MEP | 2 | MB | 1546 | CON |
| A84532 |  | Hanger and support Installation - CHW | 6d | 2019-07-27 | 2019-07-31 | A84462 SS | 92d | 0d | Mechanical Crew [60 h] | 5.66 | MEP | 2 | MB |  |  |
| A84442 |  | Duct Installation | 12d | 2019-07-28 | 2019-08-08 | A84462 SS+2d | 101.5d | 0d | Duct Installation [260 Sqmt]; HVAC [780 h] | 73.55 | MEP | 2 | MB | 1549 | CON |
| A84452 |  | Duct Insulation | 8d | 2019-07-31 | 2019-08-07 | A84442 SS+3d | 125.5d | 33d | Duct Insulation [263 Sqmt]; HVAC [190 h] | 17.92 | MEP | 2 | MB | 1552 | CON |
| A84552 |  | Chilled Water Piping Installation | 12d | 2019-07-31 | 2019-08-15 | A84532 | 92d | 0d | Mechanical Crew [120 h] | 11.32 | MEP | 2 | MB |  |  |
|  | 1.4.1.4.1.1.4.1.1.-1 | **2nd Fix** |  | 2019-08-08 | 2019-09-03 |  |  |  |  |  |  |  |  |  |  |
| A84542 |  | Installation of Duct Accessories (VD, FD, MSD etc....) | 12d | 2019-08-08 | 2019-08-22 | A84442 | 112.5d | 20d | Mechanical Crew [120 h] | 11.32 | MEP | 2 | MB |  |  |
| A84642 |  | CRAC Units Installation | 15d | 2019-08-08 | 2019-08-26 | A84442 | 101.5d | 9d | Mechanical Crew [150 h] | 14.15 | MEP | 2 | MB |  |  |
| A84652 |  | FCU Installation | 15d | 2019-08-08 | 2019-08-26 | A84442 | 101.5d | 9d | Mechanical Crew [150 h] | 14.15 | MEP | 2 | MB |  |  |
| A84662 |  | VRF DX Units Installation | 12d | 2019-08-08 | 2019-08-22 | A84442 | 104.5d | 12d | Mechanical Crew [120 h] | 11.32 | MEP | 2 | MB |  |  |
| A84672 |  | Installation of Attenuators | 10d | 2019-08-08 | 2019-08-21 | A84442 | 106.5d | 14d | Mechanical Crew [100 h] | 9.43 | MEP | 2 | MB |  |  |
| A84682 |  | Installation of HVAC Fans | 10d | 2019-08-08 | 2019-08-21 | A84442 | 106.5d | 14d | Mechanical Crew [100 h] | 9.43 | MEP | 2 | MB |  |  |
| A84702 |  | Pressurization Unit | 8d | 2019-08-08 | 2019-08-19 | A84442 | 108.5d | 16d | Mechanical Crew [80 h] | 7.54 | MEP | 2 | MB |  |  |
| A84712 |  | Dosing pot | 5d | 2019-08-08 | 2019-08-17 | A84442 | 111.5d | 19d | Mechanical Crew [50 h] | 4.71 | MEP | 2 | MB |  |  |
| A84732 |  | Air Handling Units Installation | 12d | 2019-08-08 | 2019-08-22 | A84442 | 104.5d | 12d | Mechanical Crew [120 h] | 11.32 | MEP | 2 | MB |  |  |
| A84572 |  | Valves and Accessories | 10d | 2019-08-15 | 2019-08-25 | A84552 | 92d | 0d | Mechanical Crew [100 h] | 9.43 | MEP | 2 | MB |  |  |
| A84692 |  | Air-Cooled Chillers | 15d | 2019-08-15 | 2019-08-29 | A84552 | 97.5d | 5d | Mechanical Crew [150 h] | 14.15 | MEP | 2 | MB |  |  |
| A84742 |  | Chilled Water Pump Installation | 12d | 2019-08-15 | 2019-08-26 | A84552 | 100.5d | 8d | Mechanical Crew [120 h] | 11.32 | MEP | 2 | MB |  |  |
| A84582 |  | Chilled Water Pipe Insulation and Cladding | 10d | 2019-08-25 | 2019-09-03 | A84552, A84572 | 92d | 0d | Mechanical Crew [100 h] | 9.43 | MEP | 2 | MB |  |  |

| ID | WBS | Activity | Duration | Start | Finish | Predecessors | Total float | Free float | Resources | Cost | Discipline | AREA | LOCATION | MSP Activity ID | MEP-Phase |
| --- | --- | --- | --- | --- | --- | --- | --- | --- | --- | --- | --- | --- | --- | --- | --- |
|  | 1.4.1.4.1.1.4.1.1.-2 | **HVAC_Final Fix** |  | 2019-09-03 | 2019-09-25 |  |  |  |  |  |  |  |  |  |  |
| A84722 |  | Equuipment Connection | 8d | 2019-09-03 | 2019-09-10 | A84742, A84732, A84692, A84682, A84672, A84642, A84652, A84662, A84712, A84702, A84582 | 92.5d | 0d | Mechanical Crew [80 h] | 7.54 | MEP | 2 | MB |  |  |
| A84562 |  | Air Outlets (Grills, Diffusers, Registers etc...) | 15d | 2019-09-10 | 2019-09-25 | A84542, A84442, A84452, A84722 | 92.5d | 83d | Mechanical Crew [150 h] | 14.15 | MEP | 2 | MB |  |  |
|  | 1.4.1.4.1.1.4.1.2 | **PLUMBING SYSTEM** |  | 2019-07-27 | 2019-09-09 |  |  |  |  |  |  |  |  |  |  |
|  | 1.4.1.4.1.1.4.1.2.1. | **1st Fix** |  | 2019-07-27 | 2019-08-22 |  |  |  |  |  |  |  |  |  |  |
| A84322 |  | Hanger and support Installation | 10d | 2019-07-27 | 2019-08-04 | RM280 | 88d | 0d | Plumbing Crew [100 h] | 9.43 | MEP | 2 | MB | 1566 | CON |
| A84362 |  | Drainage and Vent Pipe & Fittings | 20d | 2019-07-31 | 2019-08-21 | A84322 SS+5d | 121.5d | 1d | Plumbing Crew [200 h] | 18.86 | MEP | 2 | MB | 1573 | CON |
| A84332 |  | Domestic Water Pipe & Fittings | 20d | 2019-07-31 | 2019-08-22 | A84322 SS+6d | 88d | 0d | Plumbing Crew [200 h] | 18.86 | MEP | 2 | MB | 1570 | CON |
|  | 1.4.1.4.1.1.4.1.2.-1 | **2nd Fix** |  | 2019-08-22 | 2019-09-07 |  |  |  |  |  |  |  |  |  |  |
| A84342 |  | Domestic Water Valves | 12d | 2019-08-22 | 2019-09-03 | A84332 | 88d | 0d | Plumbing Crew [120 h] | 11.32 | MEP | 2 | MB | 1571 | CON |
| A84602 |  | Sewege Pumps Installation | 5d | 2019-08-22 | 2019-08-27 | A84362, A84332 | 120.5d | 11d | Plumbing Crew [50 h] | 4.71 | MEP | 2 | MB |  |  |
| A84352 |  | Leak Test | 4d | 2019-09-03 | 2019-09-07 | A84342 | 88d | 0d | Plumbing Crew [40 h] | 3.77 | MEP | 2 | MB | 1572 | CON |
|  | 1.4.1.4.1.1.4.1.2.-2 | **PLM_Final Fix** |  | 2019-09-07 | 2019-09-09 |  |  |  |  |  |  |  |  |  |  |
| A84592 |  | Water Heaters | 2d | 2019-09-07 | 2019-09-09 | A84352, A84362, A84332 | 109.5d | 0d | Plumbing Crew [20 h] | 1.89 | MEP | 2 | MB |  |  |
| A84612 |  | Floor Drain | 2d | 2019-09-07 | 2019-09-09 | A84592 SS | 109.5d | 0d | Plumbing Crew [20 h] | 1.89 | MEP | 2 | MB |  |  |
| A84622 |  | Wash Basin / Water Closet | 2d | 2019-09-07 | 2019-09-09 | A84612 SS | 109.5d | 0d | Plumbing Crew [20 h] | 1.89 | MEP | 2 | MB |  |  |
| A84632 |  | Eye Wash | 2d | 2019-09-07 | 2019-09-09 | A84622 SS, A84602 | 109.5d | 87d | Plumbing Crew [20 h] | 1.89 | MEP | 2 | MB |  |  |
|  | 1.4.1.4.1.1.4.1.3 | **ELECTRICAL / CONTROLS** |  | 2019-07-27 | 2019-11-20 |  |  |  |  |  |  |  |  |  |  |
|  | 1.4.1.4.1.1.4.1.3.1. | **1st Fix** |  | 2019-07-27 | 2019-08-28 |  |  |  |  |  |  |  |  |  |  |
| A84422 |  | Installation of Conduits and Boxes | 12d | 2019-07-27 | 2019-08-06 | RM280 | 26d | 0d | Electrical Crew [120 h] | 11.32 | MEP | 2 | MB | 1592 | CON |
| A84432 |  | Installation of Cable Tray, Ladder and Trunk | 20d | 2019-08-06 | 2019-08-28 | A84422 | 85.5d | 0d | Electrical Crew [200 h] | 18.86 | MEP | 2 | MB | 1593 | CON |
|  | 1.4.1.4.1.1.4.1.3.-1 | **2nd Fix** |  | 2019-08-06 | 2019-11-05 |  |  |  |  |  |  |  |  |  |  |
| A84392 |  | Grounding and Bonding Installation | 20d | 2019-08-06 | 2019-08-28 | A84422 | 26d | 0d | Electrical Crew [200 h] | 18.86 | MEP | 2 | MB | 1596 | CON |
| A84752 |  | Wire Pulling | 20d | 2019-08-28 | 2019-09-16 | A84392 | 26d | 0d | Electrical Crew [200 h] | 18.86 | MEP | 2 | MB |  |  |
| A84812 |  | Installation of Bus Duct System | 20d | 2019-08-28 | 2019-09-16 | A84432 | 85.5d | 52d | Electrical Crew [200 h] | 18.86 | MEP | 2 | MB |  |  |
| A84372 |  | Power Cable Laying | 25d | 2019-09-16 | 2019-10-10 | A84752, A84392 | 26d | 0d | Electrical Crew [250 h] | 23.58 | MEP | 2 | MB | 1600 | CON |
| A84382 |  | Continuity Test - Power Cables | 4d | 2019-10-10 | 2019-10-14 | A84372 | 56.5d | 23d | Electrical Crew [40 h] | 3.77 | MEP | 2 | MB | 1601 | CON |
| A84762 |  | Installation of Central Battery Equipment | 6d | 2019-10-10 | 2019-10-16 | A84372, A84752 | 54.5d | 21d | Electrical Crew [60 h] | 5.66 | MEP | 2 | MB |  |  |
| A84772 |  | Installation of Disconnect Switch | 8d | 2019-10-10 | 2019-10-19 | A84372, A84752 | 52.5d | 19d | Electrical Crew [80 h] | 7.54 | MEP | 2 | MB |  |  |
| A84792 |  | Installation of Switch Boards (MDB, EMDB) | 15d | 2019-10-10 | 2019-10-24 | A84372, A84752 | 26d | 0d | Electrical Crew [150 h] | 14.15 | MEP | 2 | MB |  |  |
| A84802 |  | Installation of Panel Boards | 15d | 2019-10-10 | 2019-10-24 | A84372, A84752 | 26d | 0d | Electrical Crew [150 h] | 14.15 | MEP | 2 | MB |  |  |
| A84822 |  | Installation of MCC | 15d | 2019-10-10 | 2019-10-24 | A84372, A84752 | 26d | 0d | Electrical Crew [150 h] | 14.15 | MEP | 2 | MB |  |  |
| A84832 |  | Installation of Lighting Control System | 12d | 2019-10-10 | 2019-10-22 | A84372, A84752 | 29d | 3d | Electrical Crew [120 h] | 11.32 | MEP | 2 | MB |  |  |
| A84782 |  | Installation of Wiring Devices and Outlets | 12d | 2019-10-24 | 2019-11-05 | A84752, A84822, A84802, A84792, A84832 | 26d | 0d | Electrical Crew [120 h] | 11.32 | MEP | 2 | MB |  |  |

| ID | WBS | Activity | Type | Duration | Start | Finish | Predecessors | Total float | Free float | Calendar | Resources | Cost | Discipline | AREA | LOCATION | MSP Activity ID | MEP-Phase |
| --- | --- | --- | --- | --- | --- | --- | --- | --- | --- | --- | --- | --- | --- | --- | --- | --- | --- |
|  | 1.4.1.4.1.1.4.1.3.-2 | **Elec._Final Fix** |  |  | 2019-10-24 | 2019-11-20 |  |  |  |  |  |  |  |  |  |  |  |
| A84842 |  | Panel Board Termination |  | 8d | 2019-10-24 | 2019-11-02 | A84792, A84802, A84822 | 43.5d | 10d |  | Electrical Crew [80 h] | 7.54 | MEP | 2 | MB |  |  |
| A84412 |  | Wiring devices Termination |  | 6d | 2019-11-05 | 2019-11-11 | A84762, A84772, A84812, A84832, A84782, A84382 | 33.5d | 0d |  | Electrical Crew [60 h] | 5.66 | MEP | 2 | MB | 1617 | CON |
| A84402 |  | Lighting Fixtures Installation and Termination |  | 10d | 2019-11-11 | 2019-11-20 | A84372, A84752, A84842, A84412 | 33.5d | 19d |  | Electrical Crew [100 h] | 9.43 | MEP | 2 | MB | 1616 | CON |
|  | 1.4.1.4.1.1.4.1.4 | **FIRE FIGHTING SYSTEM** |  |  | 2019-07-27 | 2019-11-02 |  |  |  |  |  |  |  |  |  |  |  |
|  | 1.4.1.4.1.1.4.1.4.1. | **1st Fix** |  |  | 2019-07-27 | 2019-09-09 |  |  |  |  |  |  |  |  |  |  |  |
| A84502 |  | Fire Fighting Hangers & Supports |  | 15d | 2019-07-27 | 2019-08-08 | RM280 | 55d | 0d |  | Fire Fighting Crew [150 h] | 14.15 | MEP | 2 | MB | 1622 | CON |
| A84472 |  | Pipe Installation |  | 30d | 2019-08-13 | 2019-09-09 | A84502 | 55d | 0d |  | FF pipe [206 Limt]; FIRE FIGHTING [361 h] | 34.04 | MEP | 2 | MB | 1625 | CON |
|  | 1.4.1.4.1.1.4.1.4.-1 | **2nd Fix** |  |  | 2019-09-10 | 2019-10-09 |  |  |  |  |  |  |  |  |  |  |  |
| A84482 |  | Valve and Accessories Installation |  | 20d | 2019-09-10 | 2019-09-30 | A84472, A84502 | 55d | 0d |  | Fire Fighting Crew [200 h] | 18.86 | MEP | 2 | MB | 1627 | CON |
| A84492 |  | Leak Test |  | 10d | 2019-09-30 | 2019-10-09 | A84482 | 55d | 0d |  | Fire Fighting Crew [100 h] | 9.43 | MEP | 2 | MB | 1631 | CON |
|  | 1.4.1.4.1.1.4.1.4.-2 | **FF_Final Fix** |  |  | 2019-10-09 | 2019-11-02 |  |  |  |  |  |  |  |  |  |  |  |
| A84512 |  | Installation of Sprinklers |  | 15d | 2019-10-09 | 2019-10-23 | A84472, A84482, A84492 | 58.5d | 0d |  | Fire Fighting Crew [150 h] | 14.15 | MEP | 2 | MB | 1633 | CON |
| A84522 |  | Instalaltion of Fire Extinguisher |  | 10d | 2019-10-23 | 2019-11-02 | A84472, A84512 | 118.5d | 119d |  | Fire Fighting Crew [100 h] | 9.43 | MEP | 2 | MB |  | CON |
| A84852 |  | Installation of Fire hose Cabinet |  | 5d | 2019-10-23 | 2019-10-28 | A84472, A84512 | 58.5d | 59d |  | Fire Fighting Crew [50 h] | 4.71 | MEP | 2 | MB |  |  |
|  | 1.5 | **TESTING AND COMMISSIONING** |  |  | 2019-11-28 | 2020-03-23 |  |  |  |  |  |  |  |  |  |  |  |
| LOE-SUM4-010 |  | Testing / Commissioning / Punch list (Part 1) | level of effort | 123.75d | 2019-11-28 | 2020-03-23 | RMLC2C100984 SS | -0.5d | 0d | Saudi |  |  | MEP |  |  |  |  |
|  | 1.5.1.5.1 | **GENERAL** |  |  | 2019-11-28 | 2020-03-15 |  |  |  |  |  |  |  |  |  |  |  |
| RMLC2C100984 |  | POWER SYSTEM |  | 90d | 2019-11-28 | 2020-02-20 | A82252, CM190, CM200, CM210, CM220, CM230 | 24.5d | 10d |  |  |  | MEP |  | MB | 1519 | TES |
| RMLC2C100983 |  | PLUMBING SYSTEM |  | 90d | 2019-12-01 | 2020-02-22 | A82472, A4712, A6872, A9032, A11192, A13352, A15512, A17672, A19832, A21992, A24152, A26312, A28472, A30632, A32792, A34952, A37112, A39272, A84884, A84938, A84992, A85100, A85046, A43592, A45752, A47912, A52232, A50072, A54392, A56552, A58712, A60872, A63032, A65192, A67352, A69512, A71672, A73832, A75992, A78152, A80312, A84632 | 22.5d | 23d |  |  |  | MEP |  | MB | 1518 | TES |
| RMLC2C100985 |  | LIGHTINING SYSTEM |  | 90d | 2019-12-08 | 2020-03-01 | RMLC2C100984 SS, A84861, A84915, A84969, A85077, A85023, A4482, A6642, A8802, A10962, A13122, A15282, A17442, A19602, A21762, A23922, A26082, A28242, A30402, A32562, A34722, A36882, A39042, A43362, A45522, A47682, A52002, A49842, A54162, A56322, A58482, A60642, A62802, A64962, A67122, A69282, A71442 SS, A73602, A75762, A77922, A80082, A82242, A84402, A41202 | 14.5d | 15d |  |  |  | MEP |  | MB | 1520 | TES |
| RMLC2C100982 |  | HVAC SYSTEM |  | 90d | 2019-12-12 | 2020-03-05 | A82562, A4642, A6802, A8962, A11122, A13282, A15442, A17602, A19762, A21922, A24082, A26242, A28402, A30562, A32722, A34882, A37042, A39202, A84877, A84931, A84985, A85093, A85039, A43522, A45682, A47842, A52162, A50002, A54322, A56482, A58642, A60802, A62962, A65122, A67282, A69442, A71602, A73762, A75922, A78082, A80242, A82402, A84562, A41362 | 9.5d | 10d |  |  |  | MEP |  | MB | 1517 | TES |
| RMLC2C100986 |  | FIRE FIGHTING SYSTEM |  | 90d | 2019-12-22 | 2020-03-15 | A84852, A82692, A71562, 54, A4592, A6752, A8912, A11072, A13232, A15392, A17552, A19712, A21872, A24032, A26192, A28352, A30512, A32672, A34832, A36992, A39152, A84872, A84926, A84980, A85088, A85034, A43472, A45632, A47792, A52112, A49952, A54272, A56432, A58592, A60752, A62912, A65072, A67232, A69392, A71552, A73712, A75872, A78032, A80192, A82352, A84512 | -0.5d | 0d |  |  |  | MEP |  | MB | 1521 | TES |
| RMLC2C100987 |  | COMMISSIONING COMPLETE | milestone | 0d | 2020-03-15 | 2020-03-15 | RMLC2C100982, RMLC2C100983, RMLC2C100984, RMLC2C100985, RMLC2C100986 | -0.5d | 0d |  |  |  | MEP |  | MB | 1522 | TES |

| ID | WBS | Activity | Type | Duration | Start | Finish | Predecessors | Total float | Free float | Constraint | Calendar | Resources | Cost | Discipline | MSP Activity ID | MEP-Phase | LOCATION |
| --- | --- | --- | --- | --- | --- | --- | --- | --- | --- | --- | --- | --- | --- | --- | --- | --- | --- |
|  | 1.6 | **HANDING OVER OF PART 1** |  |  | 2020-02-05 | 2020-03-23 |  |  |  |  |  |  |  |  |  |  |  |
| CLO020 |  | Punchlist _Civil & Archl |  | 50d | 2020-02-05 | 2020-03-23 | C1C1111F5AY1-270, 1F5-FNS-P06-1060, 1F5-FNS-P06-660, 1F5-FNS-P06-220, 1F5-FNS-NWE-260, C1C1111F5N2140, C1C1111F5NEE-3330, 1F5-FNS-P06-1120, CM380 FF, C1C1111F5NWE-330, 1F5-FNS-B03-650, C1C1111F5S1780, C1C1111F5N3040 FF+22.5d, 1F5-FNS-P06-440, 1F5-FNS-ACY2-260, 1F5-FNS-B02-660, CM350, 1F5-FNS-B05-3580, 1F5-FNS-B04-1090, CLO010 FF+1.25d, CM150, CM160, CM170, CM140, CM100, CM110, CM120, CM130, LOE-SUM4-010 FF | -0.5d | 0d |  |  | Unskilled Labour [8580 h]; Skilled Labour [11440 h] | 1,525.72 | Arch'l |  |  |  |
| CLO010 |  | Punch List_MEP |  | 32.5d | 2020-02-20 | 2020-03-22 | RMLC2C100987 FF+7.5d, A4602, A6762, A8922, A11082, A13242, A15402, A17562, A19722, A21882, A24042, A26202, A28362, A30522, A32682, A34842, A37002, A39162, A84873, A84927, A84981, A85089, A85035, A43482, A45642, A47802, A52122, A49962, A54282, A56442, A58602, A60762, A62922, A65082, A67242, A69402, A71562, A73722, A75882, A78042, A80202, A82362, A84522, A71892, A41652, A41432, A41362, A41322, CM370, CM360 | -0.5d | 0d |  |  | Fire Fighting Crew [1859 h]; Electrical Crew [2974.4 h]; Plumbing Crew [1487.2 h]; Mechanical Crew [2230.8 h] | 806.39 | MEP | 1524 | HAD | MB |
| CLO030 |  | Handing Over | milestone | 0d | 2020-03-23 | 2020-03-23 | CLO010, CLO020 | -0.5d | 0d |  |  |  |  | MEP | 1525 | HAD | MB |
|  | 8 | **PART 2 : 3RD NORTH WEST Entrance (3WE)** |  |  | 2020-03-05 | 2020-07-09 |  |  |  |  |  |  |  |  |  |  |  |
| LOE-SUM5-010 |  | 3WE - Civil Works | level of effort | 136.25d | 2020-03-05 | 2020-07-09 | C1C1111F53WE-590 SS | 2.5d | 0d |  | Saudi |  |  | Civil |  |  |  |
|  | 2 | **Base Slab at Tech'l Level B04 . (3WE)+ Elev Pit** |  |  | 2020-03-05 | 2020-03-31 |  |  |  |  |  |  |  |  |  |  |  |
| C1C1111F53WE-590 |  | Base slab B04 . 3WE - Waterproofing (not by ZSCC), Blinding |  | 3.75d | 2020-03-05 | 2020-03-08 | 1F5-FNS-ACY2-260 | 0d |  | start on or after 2020-03-04 |  |  |  | Civil |  |  | 3WE |
| C1C1111F53WE-600 |  | Base slab B04 . 3WE - Rebar fixing |  | 3.75d | 2020-03-09 | 2020-03-11 | C1C1111F53WE-590 | 0d |  |  |  | Helper [214.5 h]; Steel Fixer [343.2 h] | 39.21 | Civil |  |  | 3WE |
| C1C1111F53WE-610 |  | Base slab B04 . 3WE - Formwork fixing |  | 3.75d | 2020-03-12 | 2020-03-15 | C1C1111F53WE-600 | 0d |  |  |  | Helper [214.5 h]; Carpenter [429 h] | 45.24 | Civil |  |  | 3WE |
| C1C1111F53WE-620 |  | Base slab B04 . 3WE - Concrete Casting base slab |  | 2.5d | 2020-03-16 | 2020-03-17 | CM400, C1C1111F53WE-610 | 0d |  |  |  | Helper [143 h]; Mason [429 h]; Concrete Casting [300.49 CUM] | 40.21 | Civil |  |  | 3WE |
|  | 2 | **Outer & Inner Wall Tech'l Level ( B03 . (3WE)** |  |  | 2020-03-18 | 2020-03-31 |  |  |  |  |  |  |  |  |  |  |  |
| C1C1111F53WE-625 |  | B03. 3WE - Waterproofing Wall (not by ZSCC) |  | 3.75d | 2020-03-18 | 2020-03-21 | C1C1111F53WE-620 | 0d |  |  |  |  |  | Civil |  |  | 3WE |
| C1C1111F53WE-630 |  | B04 . 3WE - Rebar fixing wall / column |  | 3.75d | 2020-03-22 | 2020-03-24 | C1C1111F53WE-625 | 0d |  |  |  | Helper [171.6 h]; Steel Fixer [429 h] | 42.22 | Civil |  |  | 3WE |
| C1C1111F53WE-640 |  | B03. 3WE - Formwork fixing wall / column |  | 5d | 2020-03-25 | 2020-03-29 | C1C1111F53WE-630 | 0d |  |  |  | Helper [214.5 h]; Carpenter [715 h] | 65.34 | Civil |  |  | 3WE |
| C1C1111F53WE-650 |  | B03. 3WE - Concrete Casting & Striking wall |  | 2.5d | 2020-03-30 | 2020-03-31 | C1C1111F53WE-640 | 0d |  |  |  | Helper [143 h]; Mason [429 h]; Concrete Casting [276.22 CUM] | 40.21 | Civil |  |  | 3WE |
|  | 1 | **Base Slab at Concourse Level B03 . (3WE)** |  |  | 2020-04-01 | 2020-04-30 |  |  |  |  |  |  |  |  |  |  |  |
| C1C1111F53WE-510 |  | Base slab B03 . 3WE - Waterproofing (not by ZSCC), Blinding |  | 5d | 2020-04-01 | 2020-04-05 | C1C1111F53WE-650 | 0d |  |  |  |  |  | Civil |  |  | 3WE |
| C1C1111F53WE-520 |  | Base slab B03 . 3WE - Rebar fixing |  | 5d | 2020-04-06 | 2020-04-09 | C1C1111F53WE-510 | 0d |  |  |  | Helper [386.1 h]; Steel Fixer [686.4 h] | 75.39 | Civil |  |  | 3WE |
| C1C1111F53WE-530 |  | Base slab B03 . 3WE - Formwork fixing |  | 5d | 2020-04-09 | 2020-04-13 | C1C1111F53WE-520 FF+3.75d | 0d |  |  |  | Helper [214.5 h]; Carpenter [457.6 h] | 47.25 | Civil |  |  | 3WE |
| C1C1111F53WE-540 |  | Base slab B03 . 3WE - Concrete Casting base slab |  | 2.5d | 2020-04-14 | 2020-04-15 | C1C1111F53WE-530 | 0d |  |  |  | Helper [143 h]; Mason [429 h]; Concrete Casting [453.57 CUM] | 40.21 | Civil |  |  | 3WE |
|  | 2 | **Outer & Inner Wall Concourse Level ( B03 . 3WE)** |  |  | 2020-04-16 | 2020-04-30 |  |  |  |  |  |  |  |  |  |  |  |
| C1C1111F53WE-580 |  | B03. 3WE - Waterproofing Wall (not by ZSCC) |  | 5d | 2020-04-16 | 2020-04-20 | C1C1111F53WE-540 | 0d |  |  |  |  |  | Civil |  |  | 3WE |
| C1C1111F53WE-550 |  | B03. 3WE - Rebar fixing wall / column / staircase |  | 5d | 2020-04-21 | 2020-04-25 | C1C1111F53WE-580 | 0d |  |  |  | Helper [171.6 h]; Steel Fixer [686.4 h] | 60.31 | Civil |  |  | 3WE |
| C1C1111F53WE-560 |  | B03. 3WE - Formwork fixing wall / column / staircase |  | 5d | 2020-04-25 | 2020-04-28 | C1C1111F53WE-550 FF+3.75d | 0d |  |  |  | Helper [214.5 h]; Carpenter [715 h] | 65.34 | Civil |  |  | 3WE |
| C1C1111F53WE-570 |  | B03. 3WE - Concrete Casting & Striking wall |  | 2.5d | 2020-04-29 | 2020-04-30 | C1C1111F53WE-560 | 0d |  |  |  | Helper [143 h]; Mason [429 h]; Concrete Casting [318.11 CUM] | 40.21 | Civil |  |  | 3WE |

| ID | WBS | Activity | Type | Duration | Start | Finish | Predecessors | Total float | Free float | Resources | Cost | Discipline | LOCATION |
| --- | --- | --- | --- | --- | --- | --- | --- | --- | --- | --- | --- | --- | --- |
|  | 3 | **TV Louver Level B02 . 3WE** |  |  | 2020-05-02 | 2020-06-01 |  |  |  |  |  |  |  |
|  | 1 | **TV Louver Level ( B02 . 3WE)** |  |  | 2020-05-02 | 2020-06-01 |  |  |  |  |  |  |  |
| C1C1111F53WE-370 |  | B02. 3WE - Formwork and Slab fixing |  | 5d | 2020-05-02 | 2020-05-05 | C1C1111F53WE-570 | 0d |  | Helper [343.2 h]; Carpenter [686.4 h] | 72.38 | Civil | 3WE |
| C1C1111F53WE-380 |  | B02. 3WE - Rebar fixing |  | 5d | 2020-05-05 | 2020-05-09 | C1C1111F53WE-370 FF+3.75d | 0d |  | Helper [343.2 h]; Steel Fixer [715 h] | 74.39 | Civil | 3WE |
| C1C1111F53WE-390 |  | B02. 3WE - Concrete Casting Slab |  | 2.5d | 2020-05-10 | 2020-05-11 | C1C1111F53WE-380 | 0d |  | Helper [143 h]; Mason [514.8 h]; Concrete Casting [65.83 CUM] | 46.24 | Civil | 3WE |
| C1C1111F53WE-395 |  | B02. 3WE - Waterproofing wall (not by ZSCC) |  | 5d | 2020-05-12 | 2020-05-16 | C1C1111F53WE-390 | 0d |  |  |  | Civil | 3WE |
| C1C1111F53WE-400 |  | B02. 3WE - Rebar fixing wall / column / staircase |  | 6.25d | 2020-05-17 | 2020-05-21 | C1C1111F53WE-395 | 0d |  | Helper [457.6 h]; Steel Fixer [858 h] | 92.49 | Civil | 3WE |
| C1C1111F53WE-410 |  | B02. 3WE - Formwork fixing wall / column / staircase |  | 6.25d | 2020-05-21 | 2020-05-30 | C1C1111F53WE-400 SS+5d | 0d |  | Helper [457.6 h]; Carpenter [858 h] | 92.49 | Civil | 3WE |
| C1C1111F53WE-420 |  | B02. 3WE - Concrete Casting wall / column / staircase |  | 2.5d | 2020-05-31 | 2020-06-01 | C1C1111F53WE-410 | 0d |  | Helper [143 h]; Mason [429 h]; Concrete Casting [325.21 CUM] | 40.21 | Civil | 3WE |
|  | 4 | **Top Slab Level B01 . 3WE** |  |  | 2020-06-02 | 2020-06-13 |  |  |  |  |  |  |  |
|  | 1 | **Top Slab Level ( B01 . 3WE )** |  |  | 2020-06-02 | 2020-06-13 |  |  |  |  |  |  |  |
| C1C1111F53WE-440 |  | B01. 3WE - Formwork and Slab fixing |  | 5d | 2020-06-02 | 2020-06-06 | C1C1111F53WE-420 | 0d |  | Helper [343.2 h]; Carpenter [686.4 h] | 72.38 | Civil | 3WE |
| C1C1111F53WE-450 |  | B01. 3WE - Rebar fixing |  | 5d | 2020-06-07 | 2020-06-10 | C1C1111F53WE-440 | 0d |  | Helper [343.2 h]; Steel Fixer [715 h] | 74.39 | Civil | 3WE |
| C1C1111F53WE-460 |  | B01. 3WE - Concrete Casting Slab |  | 2.5d | 2020-06-11 | 2020-06-13 | C1C1111F53WE-450 | 0d |  | Helper [143 h]; Mason [514.8 h]; Concrete Casting [85.39 CUM] | 46.24 | Civil | 3WE |
|  | 5 | **Paraphet Wall above Top Slab B01 . 3WE** |  |  | 2020-06-14 | 2020-07-09 |  |  |  |  |  |  |  |
|  | 1 | **Paraphet Wall above Top Slab ( B01 . 3WE)** |  |  | 2020-06-14 | 2020-07-09 |  |  |  |  |  |  |  |
| C1C1111F53WE-470 |  | B01. 3WE - Rebar fixing column / wall / staircase |  | 6.25d | 2020-06-14 | 2020-06-18 | C1C1111F53WE-460, C1C1111F53WE-700 FF | 0d |  | Helper [357.5 h]; Steel Fixer [858 h] | 85.45 | Civil | 3WE |
| C1C1111F53WE-480 |  | B01. 3WE - Formwork fixing column / wall/ staircase |  | 6.25d | 2020-06-17 | 2020-06-22 | C1C1111F53WE-470 FF+3.75d, C1C1111F53WE-710 FF | 0d |  | Helper [343.2 h]; Carpenter [858 h] | 84.45 | Civil | 3WE |
| C1C1111F53WE-490 |  | B01. 3WE - Concrete Casting column / wall / staircase |  | 2.5d | 2020-06-23 | 2020-06-24 | C1C1111F53WE-690 FF, C1C1111F53WE-480 | 0d |  | Helper [143 h]; Mason [429 h]; Concrete Casting [234.61 CUM] | 40.21 | Civil | 3WE |
| C1C1111F53WE-500 |  | B01. 3WE - Waterproofing wall (not by ZSCC) |  | 5d | 2020-06-25 | 2020-06-29 | C1C1111F53WE-490 | 2.5d | 0d |  |  | Civil | 3WE |
| C1C1111F53WE-680 |  | B01. 3WE - Protection Screed |  | 3.75d | 2020-06-30 | 2020-07-02 | C1C1111F53WE-500 | 2.5d | 0d | Mason [257.4 h]; Helper [128.7 h] | 27.15 | Civil | 3WE |
| C1C1111F53WE-670 |  | B01. 3WE - Backfilling & compaction (Optional) |  | 7.5d | 2020-07-04 | 2020-07-09 | C1C1111F53WE-680, LOE-SUM5-010 FF | 2.5d | 0d | Helper [514.8 h] | 36.19 | Civil | 3WE |
|  | 11 | **LOE Commodities Civil - 3WE ( B01 to B03)** |  |  | 2020-03-09 | 2020-06-24 |  |  |  |  |  |  |  |
| C1C1111F53WE-700 |  | LOE - 3WE . B03 to B01 - Rebar | level of effort | 106.25d | 2020-03-09 | 2020-06-18 | C1C1111F53WE-600 SS | 0d |  | Steel Reinforcement [402.43 tons] |  | Civil | 3WE |
| C1C1111F53WE-710 |  | LOE - 3WE . B03 to B01 - Formworks | level of effort | 106.25d | 2020-03-12 | 2020-06-22 | C1C1111F53WE-610 SS | 0d |  | Formworks [4162.4 Square Meter] |  | Civil | 3WE |
| C1C1111F53WE-690 |  | LOE - 3WE . B03 to B01 - LOE - Mass concrete infill | level of effort | 105d | 2020-03-16 | 2020-06-24 | C1C1111F53WE-620 SS | 0d |  | Concrete infill [270 CUM] |  | Civil | NEE |

| ID | WBS | Activity | Type | Duration | Start | Finish | Predecessors | Total float | Free float | Calendar | Resources | Cost | Discipline | 1F4 PROJECT | LOCATION |
| --- | --- | --- | --- | --- | --- | --- | --- | --- | --- | --- | --- | --- | --- | --- | --- |
|  | 4 | **Archl Works at 3RD West Entrance (3WE)** |  |  | 2020-05-30 | 2020-09-01 |  |  |  |  |  |  |  |  |  |
| LOE-SUM5-020 |  | 3WE - Archl Works | level of effort | 102.5d | 2020-05-30 | 2020-09-01 | 1F5-FNS-3WE-010 SS | 0d |  | Saudi |  |  | Arch'l |  |  |
|  | 1 | **3WE . CONCOURSE LEVEL (B03, incl below)** |  |  | 2020-05-30 | 2020-08-17 |  |  |  |  |  |  |  |  |  |
| 1F5-FNS-3WE-010 |  | B03 . 3WE -Block Masonry |  | 12.5d | 2020-05-30 | 2020-06-09 | C1C1111F53WE-390 FS+15d | 11.25d | 0d |  | Unskilled Labour [286 h]; Skilled Labour [572 h] | 65.39 | Arch'l | 1F4CVL | 3WE |
| 1F5-FNS-3WE-020 |  | B03 . 3WE -Interior Plaster & Rendering |  | 10d | 2020-06-07 | 2020-06-15 | 1F5-FNS-3WE-010 FF+6.25d | 12.5d | 0d |  | Skilled Labour [429 h]; Unskilled Labour [257.4 h] | 52.31 | Arch'l | 1F4CVL | 3WE |
| 1F5-FNS-3WE-030 |  | B03 . 3WE -Gypsum Partition and Panel |  | 7.5d | 2020-06-11 | 2020-06-17 | 1F5-FNS-3WE-020 FF+2.5d | 12.5d | 0d |  | Skilled Labour [257.4 h]; Unskilled Labour [85.8 h] | 26.16 | Arch'l |  | 3WE |
| 1F5-FNS-3WE-040 |  | B03 . 3WE -Ceiling Painting 1st Coat |  | 6.25d | 2020-06-18 | 2020-06-23 | 1F5-FNS-3WE-010, 1F5-FNS-3WE-030 | 12.5d | 0d |  | Skilled Labour [178.75 h]; Unskilled Labour [143 h] | 24.52 | Arch'l | 1F4CVL | 3WE |
| 1F5-FNS-3WE-050 |  | B03 . 3WE -Walls Painting 1st Coat |  | 7.5d | 2020-06-24 | 2020-06-30 | 1F5-FNS-3WE-040, 1F5-FNS-3WE-020 FS+2.5d | 12.5d | 0d |  | Skilled Labour [214.5 h]; Unskilled Labour [214.5 h] | 32.7 | Arch'l | 1F4CVL | 3WE |
| 1F5-FNS-3WE-060 |  | B03 . 3WE -Floor Concreted Screeding |  | 7.5d | 2020-07-01 | 2020-07-07 | 1F5-FNS-3WE-050 | 12.5d | 0d |  | Unskilled Labour [171.6 h]; Skilled Labour [171.6 h] | 26.16 | Arch'l | 1F4CVL | 3WE |
| 1F5-FNS-3WE-070 |  | B03 . 3WE -Raised Flooring |  | 6.25d | 2020-07-08 | 2020-07-13 | 1F5-FNS-3WE-060 | 12.5d | 0d |  | Skilled Labour [214.5 h]; Unskilled Labour [143 h] | 27.25 | Arch'l | 1F4CVL | 3WE |
| 1F5-FNS-3WE-080 |  | B03 . 3WE -Install Ceiling |  | 7.5d | 2020-07-14 | 2020-07-20 | 1F5-FNS-3WE-070 | 12.5d | 0d |  | Unskilled Labour [171.6 h]; Skilled Labour [228.8 h] | 30.52 | Arch'l | 1F4CVL | 3WE |
| 1F5-FNS-3WE-090 |  | B03 . 3WE -Install Floor Tiles |  | 7.5d | 2020-07-21 | 2020-07-27 | 1F5-FNS-3WE-080 | 12.5d | 0d |  | Skilled Labour [257.4 h]; Unskilled Labour [128.7 h] | 29.43 | Arch'l | 1F4CVL | 3WE |
| 1F5-FNS-3WE-100 |  | B03 . 3WE -Ceiling Final Painting |  | 7.5d | 2020-07-28 | 2020-08-06 | 1F5-FNS-3WE-090 | 12.5d | 0d |  | Skilled Labour [214.5 h]; Unskilled Labour [128.7 h] | 26.16 | Arch'l | 1F4CVL | 3WE |
| 1F5-FNS-3WE-110 |  | B03 . 3WE -Walls Final Painting |  | 7.5d | 2020-08-08 | 2020-08-13 | 1F5-FNS-3WE-100 | 12.5d | 0d |  | Unskilled Labour [128.7 h]; Skilled Labour [214.5 h] | 26.16 | Arch'l | 1F4CVL | 3WE |
| 1F5-FNS-3WE-120 |  | B03 . 3WE -Floor Epoxy Painting |  | 6.25d | 2020-08-12 | 2020-08-17 | 1F5-FNS-3WE-110 FF+3.75d, 1F5-FNS-3WE-100 | 12.5d | 0d |  | Skilled Labour [214.5 h]; Unskilled Labour [143 h] | 27.25 | Arch'l | 1F4CVL | 3WE |
| 1F5-FNS-3WE-130 |  | B03 . 3WE -Install Door & Hardware/Accessories |  | 3.75d | 2020-08-15 | 2020-08-17 | 1F5-FNS-3WE-120 FF | 12.5d |  |  | Skilled Labour [85.8 h]; Unskilled Labour [57.2 h] | 10.9 | Arch'l | 1F4CVL | 3WE |
|  | 2 | **3WE . TV LOUVER LEVEL (B02, incl above)** |  |  | 2020-06-21 | 2020-09-01 |  |  |  |  |  |  |  |  |  |
| 1F5-FNS-3WE-140 |  | B02 . 3WE -Block Masonry |  | 12.5d | 2020-06-21 | 2020-07-01 | 1F5-FNS-3WE-300 FF, 1F5-FNS-3WE-010, C1C1111F53WE-460 FS+7.5d, 1F5-FNS-3WE-020 SS | 0d |  |  | Unskilled Labour [286 h]; Skilled Labour [572 h] | 65.39 | Arch'l | 1F4CVL | 3WE |
| 1F5-FNS-3WE-150 |  | B02 . 3WE -Interior Plaster & Rendering |  | 10d | 2020-06-28 | 2020-07-06 | 1F5-FNS-3WE-140 FF+5d, 1F5-FNS-3WE-310 FF | 0d |  |  | Skilled Labour [429 h]; Unskilled Labour [257.4 h] | 52.31 | Arch'l | 1F4CVL | 3WE |
| 1F5-FNS-3WE-160 |  | B02 . 3WE -Gypsum Partition and Panel |  | 7.5d | 2020-07-07 | 2020-07-13 | 1F5-FNS-3WE-150 | 0d |  |  | Skilled Labour [257.4 h]; Unskilled Labour [85.8 h] | 26.16 | Arch'l |  | 3WE |
| 1F5-FNS-3WE-170 |  | B02 . 3WE -Ceiling Painting 1st Coat |  | 6.25d | 2020-07-14 | 2020-07-19 | 1F5-FNS-3WE-140, 1F5-FNS-3WE-160 | 0d |  |  | Skilled Labour [178.75 h]; Unskilled Labour [143 h] | 24.52 | Arch'l | 1F4CVL | 3WE |
| 1F5-FNS-3WE-180 |  | B02 . 3WE -Walls Painting 1st Coat |  | 7.5d | 2020-07-20 | 2020-07-26 | 1F5-FNS-3WE-320 FF, 1F5-FNS-3WE-170, 1F5-FNS-3WE-150 FS+2.5d | 0d |  |  | Skilled Labour [214.5 h]; Unskilled Labour [214.5 h] | 32.7 | Arch'l | 1F4CVL | 3WE |
| 1F5-FNS-3WE-190 |  | B02 . 3WE -Floor Concreted Screeding |  | 7.5d | 2020-07-27 | 2020-08-05 | 1F5-FNS-3WE-330 FF, 1F5-FNS-3WE-180 | 0d |  |  | Unskilled Labour [171.6 h]; Skilled Labour [171.6 h] | 26.16 | Arch'l | 1F4CVL | 3WE |
| 1F5-FNS-3WE-200 |  | B02 . 3WE -Raised Flooring |  | 6.25d | 2020-08-04 | 2020-08-09 | 1F5-FNS-3WE-190 FF+3.75d | 0d |  |  | Skilled Labour [214.5 h]; Unskilled Labour [143 h] | 27.25 | Arch'l | 1F4CVL | 3WE |
| 1F5-FNS-3WE-210 |  | B02 . 3WE -Install Ceiling |  | 7.5d | 2020-08-09 | 2020-08-15 | 1F5-FNS-3WE-200 FF+6.25d, 1F5-FNS-3WE-180 | 0d |  |  | Unskilled Labour [171.6 h]; Skilled Labour [228.8 h] | 30.52 | Arch'l | 1F4CVL | 3WE |
| 1F5-FNS-3WE-220 |  | B02 . 3WE -Install Floor Tiles |  | 7.5d | 2020-08-16 | 2020-08-22 | 1F5-FNS-3WE-210 | 0d |  |  | Skilled Labour [257.4 h]; Unskilled Labour [128.7 h] | 29.43 | Arch'l | 1F4CVL | 3WE |
| 1F5-FNS-3WE-230 |  | B02 . 3WE -Ceiling Final Painting |  | 7.5d | 2020-08-19 | 2020-08-25 | 1F5-FNS-3WE-220 FF+3.75d | 0d |  |  | Skilled Labour [214.5 h]; Unskilled Labour [128.7 h] | 26.16 | Arch'l | 1F4CVL | 3WE |
| 1F5-FNS-3WE-240 |  | B02 . 3WE -Walls Final Painting |  | 7.5d | 2020-08-23 | 2020-08-29 | 1F5-FNS-3WE-230 FF+3.75d, PRO-030 FF | 0d |  |  | Unskilled Labour [128.7 h]; Skilled Labour [214.5 h] | 26.16 | Arch'l | 1F4CVL | 3WE |
| 1F5-FNS-3WE-250 |  | B02 . 3WE -Floor Epoxy Painting |  | 6.25d | 2020-08-27 | 2020-09-01 | 1F5-FNS-3WE-240 FF+3.75d, 1F5-FNS-3WE-340 FF, 1F5-FNS-3WE-230 | 0d |  |  | Skilled Labour [214.5 h]; Unskilled Labour [143 h] | 27.25 | Arch'l | 1F4CVL | 3WE |
| 1F5-FNS-3WE-260 |  | B02 . 3WE -Install Door & Hardware/Accessories |  | 3.75d | 2020-08-30 | 2020-09-01 | 1F5-FNS-3WE-130, 1F5-FNS-3WE-250 FF, PRO-010 FF, LOE-SUM5-020 FF | 0d |  |  | Skilled Labour [85.8 h]; Unskilled Labour [57.2 h] | 10.9 | Arch'l | 1F4CVL | 3WE |

| ID | WBS | Activity | Type | Duration | Start | Finish | Predecessors | Total float | Free float | Calendar | Resources | Cost | Discipline | LOCATION |
| --- | --- | --- | --- | --- | --- | --- | --- | --- | --- | --- | --- | --- | --- | --- |
|  | 11 | **LOE Commodities Archl 3WE ( B01 to B03)** |  |  | 2020-05-30 | 2020-09-01 |  |  |  |  |  |  |  |  |
| 1F5-FNS-3WE-300 |  | LOE Commodities Archl 3WE ( B01 to B03) - Blockworks | level of effort | 36.25d | 2020-05-30 | 2020-07-01 | 1F5-FNS-3WE-010 SS | 0d |  |  | Block Work [400 Square Meter] |  | Arch'l | 3WE |
| 1F5-FNS-3WE-310 |  | LOE Commodities Archl 3WE ( B01 to B03) - Plastering | level of effort | 32.5d | 2020-06-07 | 2020-07-06 | 1F5-FNS-3WE-020 SS | 0d |  |  | Plaster Work [839 Square Meter] |  | Arch'l | 3WE |
| 1F5-FNS-3WE-320 |  | LOE Commodities Archl 3WE ( B01 to B03) - Painting | level of effort | 41.25d | 2020-06-18 | 2020-07-26 | 1F5-FNS-3WE-040 SS | 0d |  |  | Painting [675 Square Meter] |  | Arch'l | 3WE |
| 1F5-FNS-3WE-330 |  | LOE Commodities Archl 3WE ( B01 to B03) - Screed | level of effort | 35d | 2020-07-01 | 2020-08-05 | 1F5-FNS-3WE-060 SS | 0d |  |  | Screed Work [322 Square Meter] |  | Arch'l | 3WE |
| 1F5-FNS-3WE-340 |  | LOE Commodities Archl 3WE ( B01 to B03) - Final Painting | level of effort | 50d | 2020-07-14 | 2020-09-01 | 1F5-FNS-3WE-080 SS | 0d |  |  | Painting [225 Square Meter] |  | Arch'l | 3WE |
|  | 6 | **CLOSED OUT** |  |  | 2020-07-01 | 2020-09-22 |  |  |  |  |  |  |  |  |
| CLO-100 |  | Complete Testing & commissioning |  | 65d | 2020-07-01 | 2020-09-02 | 1F5-FNS-3WE-250 FF+1.25d, PRO-020 FF, A33012 | 6.25d | 3.75d |  | Mechanical Crew [1040 h]; FIRE FIGHTING [1040 h]; Electrical Crew [1040 h] | 294.21 | MEP |  |
| LOE-SUM5-030 |  | Testing / Commissioning / Punch list (Part 2 - Last Part) | level of effort | 78.75d | 2020-07-01 | 2020-09-12 | CLO-100 SS | 2.5d | 0d | Saudi |  |  | MEP |  |
| CLO-110 |  | Final Punch list |  | 65d | 2020-07-11 | 2020-09-12 | CLO-100 FF+6.25d, PRO-010 FF, C1C1111F53WE-670, CM390, LOE-SUM5-030 FF | 2.5d | 0d |  | Unskilled Labour [1040 h]; Skilled Labour [1560 h] | 198.15 | Arch'l |  |
| CLO-120 |  | Site Clearing |  | 32.5d | 2020-08-18 | 2020-09-16 | CLO-110 FF+5d | 2.5d |  |  | Unskilled Labour [1040 h]; Skilled Labour [1040 h] | 158.52 | Arch'l |  |
| LOE-SUM5-040 |  | Handing-0ver & Demobilization | level of effort | 38.75d | 2020-08-18 | 2020-09-22 | CLO-120 SS | 0d |  | Saudi |  |  | Civil |  |
| CLO-130 |  | Handing over & demobilization |  | 15d | 2020-09-09 | 2020-09-22 | CLO-120 FF+3.75d, CM410, CM420, LOE-SUM5-040 FF | 0d |  |  | 1F5-MOB [1744 h] | 801.37 |  |  |

## Activity codes

| Code | Value | Meaning |
| --- | --- | --- |
| 1F4 PROJECT | 1F4CVL | CIVIL WORKS |
| AREA | 1 | AREA-1 |
| AREA | 2 | AREA-2 |
| AREA | 3 | AREA-3 |
| AREA | 4 | AREA-4 |
| AREA | 5 | AREA-5 |
| LOCATION | 3WE | 3RD WEST ENTR |
| LOCATION | MB | MAIN BOX |
| LOCATION | NEE | NORTH EAST ENTR |
| LOCATION | NWE | NORTH WEST ENTR |
| MEP-Phase | CON | CONSTRUCTION |
| MEP-Phase | ENG | ENGINEERING |
| MEP-Phase | HAD | HANDING OVER |
| MEP-Phase | PRC | PROCUREMENT |
| MEP-Phase | TES | TESTING |
| MILESTONE | 02 | RC up to Techl Floor at South |
| MILESTONE | 03 | RC up to Roof Slab (B01) South |
| MILESTONE | 06 | RC up to Techl Floor at Central |
| MILESTONE | 07 | RC up to Roof Slab (B01) Central |
| MILESTONE | 09 | RC to Base Raft at North |
| MILESTONE | 10 | RC to Base Slab & Inner Wall at North |
| MILESTONE | 11 | RC up to Techl Floor at North |
| MILESTONE | 12 | RC up to Roof Slab (B01) North |

# RIYADH METRO PROJECT - TURNKEY WORKS-1F5

Schedule from Primavera P6, 2018-08-29 to 2019-05-23, data date 2018-08-01.
Must finish by 2020-03-30

## Calendars

- Surface Stations: Mon-Thu 07:00-12:00, 13:00-18:00; Fri off; Sat-Sun 07:00-12:00, 13:00-18:00.

## Schedule

| ID | WBS | Activity | Duration | Start | Finish | Total float | Free float |
| --- | --- | --- | --- | --- | --- | --- | --- |
|  | 1.1 | **MILESTONES** |  |  |  |  |  |
|  | 1.1.1.1.1 | **Contractual Milestones** |  |  |  |  |  |
|  | 2 | **South Main Box Base Raft (zone 8 - 11)** |  |  |  |  |  |
|  | 4 | **Central Main Box Base Raft (zone 5 - 7)** |  |  |  |  |  |
|  | 1 | **North Main Box Base Raft (zone 1 - 4)** |  |  |  |  |  |
|  | 3 | **ACY & Entrance** |  |  |  |  |  |
|  | 7 | **Access** |  |  |  |  |  |
|  | 6 | **Architectural & MEP** |  |  |  |  |  |
|  | 5 | **Completion** |  |  |  |  |  |
|  | 8 | **Hand Over from Arch. to MEP** |  |  |  |  |  |
|  | 1 | **Base Raft B07** |  |  |  |  |  |
|  | 6 | **Platform Level (P06)** |  |  |  |  |  |
|  | 5 | **Mezzanine Level (B05)** |  |  |  |  |  |
|  | 4 | **Technical Level (B04)** |  |  |  |  |  |
|  | 3 | **Concourse Level (B03)** |  |  |  |  |  |
|  | 2 | **B02 - CONCOURSE MEZZ & TV LOUVER** |  |  |  |  |  |
|  | 7 | **G00 - GROUND** |  |  |  |  |  |
|  | 9 | **Hand Over from MEP to Arch.** |  |  |  |  |  |
|  | 1 | **Base Raft B07** |  |  |  |  |  |
|  | 3 | **Platform Level (P06)** |  |  |  |  |  |
|  | 2 | **Mezzanine Level (B05)** |  |  |  |  |  |
|  | 4 | **Technical Level (B04)** |  |  |  |  |  |
|  | 5 | **Concourse Level (B03)** |  |  |  |  |  |
|  | 6 | **B02 - CONCOURSE MEZZ & TV LOUVER** |  |  |  |  |  |
|  | 7 | **G00 - GROUND** |  |  |  |  |  |
|  | 1.2 | **MEP ENGINEERING** |  | 2018-08-29 | 2018-10-15 |  |  |
|  | 1.2.1.2.2 | **Shop Drawing Preparation and Submission** |  |  |  |  |  |
|  | 1.2.1.2.2.1.2.2.2.1. | **HVAC SYSTEM** |  |  |  |  |  |
|  | 1.2.1.2.2.1.2.2.2.-1 | **PLUMBING SYSTEM** |  |  |  |  |  |
|  | 1.2.1.2.2.1.2.2.2.-2 | **ELECTRICAL / CONTROLS** |  |  |  |  |  |
|  | 1.2.1.2.2.1.2.2.2.-3 | **FIRE FIGHTING SYSTEM** |  |  |  |  |  |
|  | 1 | **Shop Drawing Review and Approval** |  |  |  |  |  |
|  | 1.2.1.2.2.1.2.2.2.1. | **HVAC SYSTEM** |  |  |  |  |  |
|  | 1.2.1.2.2.1.2.2.2.-1 | **PLUMBING SYSTEM** |  |  |  |  |  |
|  | 1.2.1.2.2.1.2.2.2.-2 | **ELECTRICAL / CONTROLS** |  |  |  |  |  |
|  | 1.2.1.2.2.1.2.2.2.-3 | **FIRE FIGHTING SYSTEM** |  |  |  |  |  |
|  | 1.2.1.2.1 | **MAR Production and Submission** |  |  |  |  |  |
|  | 1.2.2.1 | **HVAC** |  |  |  |  |  |
|  | 1.2.2.2 | **PLUMBING** |  |  |  |  |  |
|  | 1.2.2.3 | **ELECTRICAL** |  |  |  |  |  |
|  | 1.2.2.4 | **FIRE FIGHTING** |  |  |  |  |  |
|  | 2 | **MAR Review and Approval** |  | 2018-08-29 | 2018-10-15 |  |  |
|  | 1 | **HVAC** |  | 2018-08-29 | 2018-08-30 |  |  |
| RMLE2C100113 |  | Approval for Bulk Materials (Duct / Piping Hangers & Supports and Accessories) | 1d | 2018-08-29 | 2018-08-30 | 440.75d | 0d |

| ID | WBS | Activity | Duration | Start | Finish | Predecessors | Total float | Free float |
| --- | --- | --- | --- | --- | --- | --- | --- | --- |
|  | 4 | **PLUMBING** |  |  |  |  |  |  |
|  | 2 | **ELECTRICAL** |  |  |  |  |  |  |
|  | 3 | **FIRE FIGHTING** |  | 2018-10-15 | 2018-10-15 |  |  |  |
| RMLE2C100160 |  | Approval for submitted Document of Street Pillar Hydrant & Tank Fill connector | 1d | 2018-10-15 | 2018-10-15 |  | 446.5d | 0d |
|  | 1.4 | **MEP CONSTRUCTION** |  | 2019-02-11 | 2019-05-23 |  |  |  |
|  | 1.4.1 | **B07 - UNDER PLATFORM** |  | 2019-02-11 | 2019-05-23 |  |  |  |
|  | 6 | **SOUTH UNDER PLATFORM ZONE (8 TO 11)** |  | 2019-02-11 | 2019-05-23 |  |  |  |
|  | 2 | **B07 - UNDER PLATFORM ZONE 08** |  | 2019-02-11 | 2019-04-11 |  |  |  |
|  | 1.4.1.4.1.1.4.1.1 | **HVAC SYSTEM** |  | 2019-02-11 | 2019-03-20 |  |  |  |
|  | 1.4.1.4.1.1.4.1.1.1. | **1st Fix** |  | 2019-02-11 | 2019-02-27 |  |  |  |
| 1 |  | Hanger and support Installation - Duct | 6d | 2019-02-11 | 2019-02-16 | RMLP2C100071 (other project) SS | 348d | 0d |
| 4 |  | Duct Installation | 12d | 2019-02-12 | 2019-02-24 | RMLP2C100072 (other project) SS | 348d | 0d |
| 5 |  | Duct Insulation | 8d | 2019-02-16 | 2019-02-23 | RMLP2C100067 (other project) SS | 361d | 13d |
| 6 |  | Chilled Water Piping Installation | 12d | 2019-02-16 | 2019-02-27 | RMLP2C100074 (other project) SS | 350d | 0d |
|  | 1.4.1.4.1.1.4.1.1.-1 | **2nd Fix** |  | 2019-02-24 | 2019-03-18 |  |  |  |
| 07 |  | Installation of Duct Accessories (VD, FD, MSD etc....) | 12d | 2019-02-24 | 2019-03-06 | RMLP2C100068 (other project) SS | 348d | 0d |
| 19 |  | Air Handling Units Installation | 12d | 2019-02-24 | 2019-03-06 | RMLP2C100044 (other project) SS | 362d | 12d |
| 08 |  | Valves and Accessories | 10d | 2019-02-27 | 2019-03-09 | RMLP2C100070 (other project) SS | 350d | 0d |
| 09 |  | Chilled Water Pipe Insulation and Cladding | 10d | 2019-03-09 | 2019-03-18 | RMLP2C100069 (other project) SS | 350d | 0d |
|  | 1.4.1.4.1.1.4.1.1.-2 | **HVAC_Final Fix** |  | 2019-03-06 | 2019-03-20 |  |  |  |
| 22 |  | Air Outlets (Grills, Diffusers, Registers etc...) | 15d | 2019-03-06 | 2019-03-20 | RMLP2C100073 (other project) SS | 348d | 0d |
|  | 1.4.1.4.1.1.4.1.2 | **PLUMBING SYSTEM** |  | 2019-02-11 | 2019-03-18 |  |  |  |
|  | 1.4.1.4.1.1.4.1.2.1. | **1st Fix** |  | 2019-02-11 | 2019-03-06 |  |  |  |
| 23 |  | Hanger and support Installation | 10d | 2019-02-11 | 2019-02-19 | RMLP2C100077 (other project) SS | 348d | 0d |
| 25 |  | Domestic Water Pipe & Fittings | 20d | 2019-02-16 | 2019-03-06 | RMLP2C100078 (other project) SS, RMLP2C100075 (other project) SS | 348d | 0d |

| ID | WBS | Activity | Duration | Start | Finish | Predecessors | Total float | Free float |
| --- | --- | --- | --- | --- | --- | --- | --- | --- |
|  | 1.4.1.4.1.1.4.1.2.-1 | **2nd Fix** |  | 2019-03-06 | 2019-03-18 |  |  |  |
| 26 |  | Domestic Water Valves | 12d | 2019-03-06 | 2019-03-18 | RMLP2C100076 (other project) SS | 348d | 0d |
|  | 1.4.1.4.1.1.4.1.2.-2 | **PLM_Final Fix** |  |  |  |  |  |  |
|  | 1.4.1.4.1.1.4.1.3 | **ELECTRICAL / CONTROLS** |  | 2019-02-11 | 2019-03-31 |  |  |  |
|  | 1.4.1.4.1.1.4.1.3.1. | **1st Fix** |  | 2019-02-11 | 2019-03-09 |  |  |  |
| 33 |  | Installation of Conduits and Boxes | 12d | 2019-02-11 | 2019-02-21 | RMLP2C100081 (other project) SS | 274d | 0d |
| 34 |  | Installation of Cable Tray, Ladder and Trunk | 20d | 2019-02-18 | 2019-03-09 | RMLP2C100079 (other project) SS | 330d | 0d |
|  | 1.4.1.4.1.1.4.1.3.-1 | **2nd Fix** |  | 2019-02-21 | 2019-03-31 |  |  |  |
| 35 |  | Grounding and Bonding Installation | 20d | 2019-02-21 | 2019-03-12 | RMLP2C100082 (other project) SS | 274d | 0d |
| 36 |  | Wire Pulling | 20d | 2019-03-12 | 2019-03-31 | RMLP2C100080 (other project) SS | 274d | 0d |
|  | 1.4.1.4.1.1.4.1.3.-2 | **Elec._Final Fix** |  |  |  |  |  |  |
|  | 1.4.1.4.1.1.4.1.4 | **FIRE FIGHTING SYSTEM** |  | 2019-02-11 | 2019-04-11 |  |  |  |
|  | 1.4.1.4.1.1.4.1.4.1. | **1st Fix** |  | 2019-02-11 | 2019-03-24 |  |  |  |
| 50 |  | Fire Fighting Hangers & Supports | 15d | 2019-02-11 | 2019-02-24 | RMLP2C100084 (other project) SS | 294d | 0d |
| 51 |  | Pipe Installation | 30d | 2019-02-25 | 2019-03-24 | RMLP2C100085 (other project) SS | 294d | 0d |
|  | 1.4.1.4.1.1.4.1.4.-1 | **2nd Fix** |  | 2019-03-25 | 2019-04-11 |  |  |  |
| 52 |  | Valve and Accessories Installation | 20d | 2019-03-25 | 2019-04-11 | RMLP2C100083 (other project) SS | 294d | 0d |
|  | 1.4.1.4.1.1.4.1.4.-2 | **FF_Final Fix** |  |  |  |  |  |  |
|  | 1 | **B07 - UNDER PLATFORM ZONE 09** |  | 2019-02-24 | 2019-05-23 |  |  |  |
|  | 1.4.1.4.1.1.4.1.1 | **HVAC SYSTEM** |  | 2019-02-24 | 2019-03-13 |  |  |  |
|  | 1.4.1.4.1.1.4.1.1.1. | **1st Fix** |  |  |  |  |  |  |
|  | 1.4.1.4.1.1.4.1.1.-1 | **2nd Fix** |  | 2019-02-24 | 2019-03-13 |  |  |  |
| A4722 |  | CRAC Units Installation | 15d | 2019-02-24 | 2019-03-10 | RMLP2C100046 (other project) SS | 367d | 17d |
| A4732 |  | FCU Installation | 15d | 2019-02-24 | 2019-03-10 | RMLP2C100047 (other project) SS | 367d | 17d |
| A4742 |  | VRF DX Units Installation | 12d | 2019-02-24 | 2019-03-06 | RMLP2C100045 (other project) SS | 370d | 20d |
| A4762 |  | Installation of HVAC Fans | 10d | 2019-02-24 | 2019-03-05 | RMLP2C100048 (other project) SS | 372d | 22d |
| A4772 |  | Air-Cooled Chillers | 15d | 2019-02-27 | 2019-03-13 | RMLP2C100043 (other project) SS | 363d | 13d |

| ID | WBS | Activity | Duration | Start | Finish | Predecessors | Total float | Free float |
| --- | --- | --- | --- | --- | --- | --- | --- | --- |
|  | 1.4.1.4.1.1.4.1.1.-2 | **HVAC_Final Fix** |  |  |  |  |  |  |
|  | 1.4.1.4.1.1.4.1.2 | **PLUMBING SYSTEM** |  | 2019-03-11 | 2019-04-03 |  |  |  |
|  | 1.4.1.4.1.1.4.1.2.1. | **1st Fix** |  |  |  |  |  |  |
|  | 1.4.1.4.1.1.4.1.2.-1 | **2nd Fix** |  | 2019-03-11 | 2019-03-16 |  |  |  |
| A4682 |  | Sewege Pumps Installation | 5d | 2019-03-11 | 2019-03-16 | RMLP2C100049 (other project) SS | 366d | 18d |
|  | 1.4.1.4.1.1.4.1.2.-2 | **PLM_Final Fix** |  | 2019-04-02 | 2019-04-03 |  |  |  |
| A4672 |  | Water Heaters | 2d | 2019-04-02 | 2019-04-03 | RMLP2C100051 (other project) SS | 348d | 0d |
| A4702 |  | Wash Basin / Water Closet | 2d | 2019-04-02 | 2019-04-03 | RMLP2C100050 (other project) SS | 348d | 0d |
|  | 1.4.1.4.1.1.4.1.3 | **ELECTRICAL / CONTROLS** |  | 2019-03-09 | 2019-05-19 |  |  |  |
|  | 1.4.1.4.1.1.4.1.3.1. | **1st Fix** |  |  |  |  |  |  |
|  | 1.4.1.4.1.1.4.1.3.-1 | **2nd Fix** |  | 2019-03-09 | 2019-05-19 |  |  |  |
| A4892 |  | Installation of Bus Duct System | 20d | 2019-03-09 | 2019-03-27 | RMLP2C100056 (other project) SS | 340d | 56d |
| A4842 |  | Installation of Central Battery Equipment | 6d | 2019-04-23 | 2019-04-29 | RMLP2C100053 (other project) SS | 305d | 21d |
| A4882 |  | Installation of Panel Boards | 15d | 2019-04-23 | 2019-05-07 | RMLP2C100057 (other project) SS | 284d | 0d |
| A4902 |  | Installation of MCC | 15d | 2019-04-23 | 2019-05-07 | RMLP2C100055 (other project) SS | 284d | 0d |
| A4912 |  | Installation of Lighting Control System | 12d | 2019-04-23 | 2019-05-05 | RMLP2C100059 (other project) SS | 287d | 3d |
| A4862 |  | Installation of Wiring Devices and Outlets | 12d | 2019-05-07 | 2019-05-19 | RMLP2C100054 (other project) SS, RMLP2C100058 (other project) SS | 284d | 0d |
|  | 1.4.1.4.1.1.4.1.3.-2 | **Elec._Final Fix** |  |  |  |  |  |  |
|  | 1.4.1.4.1.1.4.1.4 | **FIRE FIGHTING SYSTEM** |  | 2019-03-25 | 2019-05-23 |  |  |  |
|  | 1.4.1.4.1.1.4.1.4.1. | **1st Fix** |  |  |  |  |  |  |
|  | 1.4.1.4.1.1.4.1.4.-1 | **2nd Fix** |  | 2019-03-25 | 2019-04-11 |  |  |  |
| A4562 |  | Valve and Accessories Installation | 20d | 2019-03-25 | 2019-04-11 | RMLP2C100064 (other project) SS | 304d | 0d |
|  | 1.4.1.4.1.1.4.1.4.-2 | **FF_Final Fix** |  | 2019-04-22 | 2019-05-23 |  |  |  |
| A4592 |  | Installation of Sprinklers | 15d | 2019-04-22 | 2019-05-05 | RMLP2C100065 (other project) SS | 304d | 5d |
| A4932 |  | Installation of Fire hose Cabinet | 5d | 2019-05-11 | 2019-05-14 | RMLP2C100060 (other project) SS | 304d | 209d |
| A4602 |  | Instalaltion of Fire Extinguisher | 10d | 2019-05-15 | 2019-05-23 | RMLP2C100061 (other project) SS | 294d | 199d |

| ID | WBS | Activity | Duration | Start | Finish | Predecessors | Total float | Free float |
| --- | --- | --- | --- | --- | --- | --- | --- | --- |
|  | 3 | **B07 - UNDER PLATFORM ZONE 10** |  | 2019-03-21 | 2019-03-24 |  |  |  |
|  | 1.4.1.4.1.1.4.1.1 | **HVAC SYSTEM** |  |  |  |  |  |  |
|  | 1.4.1.4.1.1.4.1.1.1. | **1st Fix** |  |  |  |  |  |  |
|  | 1.4.1.4.1.1.4.1.1.-1 | **2nd Fix** |  |  |  |  |  |  |
|  | 1.4.1.4.1.1.4.1.1.-2 | **HVAC_Final Fix** |  |  |  |  |  |  |
|  | 1.4.1.4.1.1.4.1.2 | **PLUMBING SYSTEM** |  | 2019-03-21 | 2019-03-24 |  |  |  |
|  | 1.4.1.4.1.1.4.1.2.1. | **1st Fix** |  |  |  |  |  |  |
|  | 1.4.1.4.1.1.4.1.2.-1 | **2nd Fix** |  |  |  |  |  |  |
|  | 1.4.1.4.1.1.4.1.2.-2 | **PLM_Final Fix** |  | 2019-03-21 | 2019-03-24 |  |  |  |
| A6872 |  | Eye Wash | 2d | 2019-03-21 | 2019-03-24 | RMLP2C100052 (other project) SS | 360d | 265d |
|  | 1.4.1.4.1.1.4.1.3 | **ELECTRICAL / CONTROLS** |  |  |  |  |  |  |
|  | 1.4.1.4.1.1.4.1.3.1. | **1st Fix** |  |  |  |  |  |  |
|  | 1.4.1.4.1.1.4.1.3.-1 | **2nd Fix** |  |  |  |  |  |  |
|  | 1.4.1.4.1.1.4.1.3.-2 | **Elec._Final Fix** |  |  |  |  |  |  |
|  | 1.4.1.4.1.1.4.1.4 | **FIRE FIGHTING SYSTEM** |  |  |  |  |  |  |
|  | 1.4.1.4.1.1.4.1.4.1. | **1st Fix** |  |  |  |  |  |  |
|  | 1.4.1.4.1.1.4.1.4.-1 | **2nd Fix** |  |  |  |  |  |  |
|  | 1.4.1.4.1.1.4.1.4.-2 | **FF_Final Fix** |  |  |  |  |  |  |
|  | 4 | **B07 - UNDER PLATFORM ZONE 11** |  | 2019-02-25 | 2019-05-14 |  |  |  |
|  | 1.4.1.4.1.1.4.1.1 | **HVAC SYSTEM** |  |  |  |  |  |  |
|  | 1.4.1.4.1.1.4.1.1.1. | **1st Fix** |  |  |  |  |  |  |
|  | 1.4.1.4.1.1.4.1.1.-1 | **2nd Fix** |  |  |  |  |  |  |
|  | 1.4.1.4.1.1.4.1.1.-2 | **HVAC_Final Fix** |  |  |  |  |  |  |
|  | 1.4.1.4.1.1.4.1.2 | **PLUMBING SYSTEM** |  |  |  |  |  |  |
|  | 1.4.1.4.1.1.4.1.2.1. | **1st Fix** |  |  |  |  |  |  |
|  | 1.4.1.4.1.1.4.1.2.-1 | **2nd Fix** |  |  |  |  |  |  |
|  | 1.4.1.4.1.1.4.1.2.-2 | **PLM_Final Fix** |  |  |  |  |  |  |
|  | 1.4.1.4.1.1.4.1.3 | **ELECTRICAL / CONTROLS** |  |  |  |  |  |  |
|  | 1.4.1.4.1.1.4.1.3.1. | **1st Fix** |  |  |  |  |  |  |
|  | 1.4.1.4.1.1.4.1.3.-1 | **2nd Fix** |  |  |  |  |  |  |
|  | 1.4.1.4.1.1.4.1.3.-2 | **Elec._Final Fix** |  |  |  |  |  |  |
|  | 1.4.1.4.1.1.4.1.4 | **FIRE FIGHTING SYSTEM** |  | 2019-02-25 | 2019-05-14 |  |  |  |
|  | 1.4.1.4.1.1.4.1.4.1. | **1st Fix** |  | 2019-02-25 | 2019-03-24 |  |  |  |
| A8872 |  | Pipe Installation | 30d | 2019-02-25 | 2019-03-24 | RMLP2C100066 (other project) SS | 304d | 0d |

| ID | WBS | Activity | Duration | Start | Finish | Predecessors | Total float | Free float |
| --- | --- | --- | --- | --- | --- | --- | --- | --- |
|  | 1.4.1.4.1.1.4.1.4.-1 | **2nd Fix** |  |  |  |  |  |  |
|  | 1.4.1.4.1.1.4.1.4.-2 | **FF_Final Fix** |  | 2019-05-06 | 2019-05-14 |  |  |  |
| A8922 |  | Instalaltion of Fire Extinguisher | 10d | 2019-05-06 | 2019-05-14 | RMLP2C100063 (other project) SS | 304d | 209d |
| A9252 |  | Installation of Fire hose Cabinet | 5d | 2019-05-06 | 2019-05-09 | RMLP2C100062 (other project) SS | 309d | 214d |
|  | 1 | **CENTRAL UNDER PLATFORM ZONE (5 TO 7)** |  |  |  |  |  |  |
|  | 2 | **B07 - UNDER PLATFORM ZONE 05** |  |  |  |  |  |  |
|  | 1.4.1.4.1.1.4.1.1 | **HVAC SYSTEM** |  |  |  |  |  |  |
|  | 1.4.1.4.1.1.4.1.1.1. | **1st Fix** |  |  |  |  |  |  |
|  | 1.4.1.4.1.1.4.1.1.-1 | **2nd Fix** |  |  |  |  |  |  |
|  | 1.4.1.4.1.1.4.1.1.-2 | **HVAC_Final Fix** |  |  |  |  |  |  |
|  | 1.4.1.4.1.1.4.1.2 | **PLUMBING SYSTEM** |  |  |  |  |  |  |
|  | 1.4.1.4.1.1.4.1.2.1. | **1st Fix** |  |  |  |  |  |  |
|  | 1.4.1.4.1.1.4.1.2.-1 | **2nd Fix** |  |  |  |  |  |  |
|  | 1.4.1.4.1.1.4.1.2.-2 | **PLM_Final Fix** |  |  |  |  |  |  |
|  | 1.4.1.4.1.1.4.1.3 | **ELECTRICAL / CONTROLS** |  |  |  |  |  |  |
|  | 1.4.1.4.1.1.4.1.3.1. | **1st Fix** |  |  |  |  |  |  |
|  | 1.4.1.4.1.1.4.1.3.-1 | **2nd Fix** |  |  |  |  |  |  |
|  | 1.4.1.4.1.1.4.1.3.-2 | **Elec._Final Fix** |  |  |  |  |  |  |
|  | 1.4.1.4.1.1.4.1.4 | **FIRE FIGHTING SYSTEM** |  |  |  |  |  |  |
|  | 1.4.1.4.1.1.4.1.4.1. | **1st Fix** |  |  |  |  |  |  |
|  | 1.4.1.4.1.1.4.1.4.-1 | **2nd Fix** |  |  |  |  |  |  |
|  | 1.4.1.4.1.1.4.1.4.-2 | **FF_Final Fix** |  |  |  |  |  |  |
|  | 1 | **B07 - UNDER PLATFORM ZONE 06** |  |  |  |  |  |  |
|  | 1.4.1.4.1.1.4.1.1 | **HVAC SYSTEM** |  |  |  |  |  |  |
|  | 1.4.1.4.1.1.4.1.1.1. | **1st Fix** |  |  |  |  |  |  |
|  | 1.4.1.4.1.1.4.1.1.-1 | **2nd Fix** |  |  |  |  |  |  |
|  | 1.4.1.4.1.1.4.1.1.-2 | **HVAC_Final Fix** |  |  |  |  |  |  |
|  | 1.4.1.4.1.1.4.1.2 | **PLUMBING SYSTEM** |  |  |  |  |  |  |
|  | 1.4.1.4.1.1.4.1.2.1. | **1st Fix** |  |  |  |  |  |  |
|  | 1.4.1.4.1.1.4.1.2.-1 | **2nd Fix** |  |  |  |  |  |  |
|  | 1.4.1.4.1.1.4.1.2.-2 | **PLM_Final Fix** |  |  |  |  |  |  |
|  | 1.4.1.4.1.1.4.1.3 | **ELECTRICAL / CONTROLS** |  |  |  |  |  |  |
|  | 1.4.1.4.1.1.4.1.3.1. | **1st Fix** |  |  |  |  |  |  |
|  | 1.4.1.4.1.1.4.1.3.-1 | **2nd Fix** |  |  |  |  |  |  |
|  | 1.4.1.4.1.1.4.1.3.-2 | **Elec._Final Fix** |  |  |  |  |  |  |
|  | 1.4.1.4.1.1.4.1.4 | **FIRE FIGHTING SYSTEM** |  |  |  |  |  |  |
|  | 1.4.1.4.1.1.4.1.4.1. | **1st Fix** |  |  |  |  |  |  |
|  | 1.4.1.4.1.1.4.1.4.-1 | **2nd Fix** |  |  |  |  |  |  |
|  | 1.4.1.4.1.1.4.1.4.-2 | **FF_Final Fix** |  |  |  |  |  |  |
|  | 3 | **B07 - UNDER PLATFORM ZONE 07** |  |  |  |  |  |  |
|  | 1.4.1.4.1.1.4.1.1 | **HVAC SYSTEM** |  |  |  |  |  |  |
|  | 1.4.1.4.1.1.4.1.1.1. | **1st Fix** |  |  |  |  |  |  |
|  | 1.4.1.4.1.1.4.1.1.-1 | **2nd Fix** |  |  |  |  |  |  |
|  | 1.4.1.4.1.1.4.1.1.-2 | **HVAC_Final Fix** |  |  |  |  |  |  |
|  | 1.4.1.4.1.1.4.1.2 | **PLUMBING SYSTEM** |  |  |  |  |  |  |
|  | 1.4.1.4.1.1.4.1.2.1. | **1st Fix** |  |  |  |  |  |  |
|  | 1.4.1.4.1.1.4.1.2.-1 | **2nd Fix** |  |  |  |  |  |  |
|  | 1.4.1.4.1.1.4.1.2.-2 | **PLM_Final Fix** |  |  |  |  |  |  |
|  | 1.4.1.4.1.1.4.1.3 | **ELECTRICAL / CONTROLS** |  |  |  |  |  |  |
|  | 1.4.1.4.1.1.4.1.3.1. | **1st Fix** |  |  |  |  |  |  |
|  | 1.4.1.4.1.1.4.1.3.-1 | **2nd Fix** |  |  |  |  |  |  |
|  | 1.4.1.4.1.1.4.1.3.-2 | **Elec._Final Fix** |  |  |  |  |  |  |
|  | 1.4.1.4.1.1.4.1.4 | **FIRE FIGHTING SYSTEM** |  |  |  |  |  |  |
|  | 1.4.1.4.1.1.4.1.4.1. | **1st Fix** |  |  |  |  |  |  |
|  | 1.4.1.4.1.1.4.1.4.-1 | **2nd Fix** |  |  |  |  |  |  |
|  | 1.4.1.4.1.1.4.1.4.-2 | **FF_Final Fix** |  |  |  |  |  |  |
|  | 2 | **NORTH UNDER PLATFORM ZONE (1 TO 4)** |  |  |  |  |  |  |
|  | 2 | **B07 - UNDER PLATFORM ZONE 01** |  |  |  |  |  |  |
|  | 1.4.1.4.1.1.4.1.1 | **HVAC SYSTEM** |  |  |  |  |  |  |
|  | 1.4.1.4.1.1.4.1.1.1. | **1st Fix** |  |  |  |  |  |  |
|  | 1.4.1.4.1.1.4.1.1.-1 | **2nd Fix** |  |  |  |  |  |  |
|  | 1.4.1.4.1.1.4.1.1.-2 | **HVAC_Final Fix** |  |  |  |  |  |  |
|  | 1.4.1.4.1.1.4.1.2 | **PLUMBING SYSTEM** |  |  |  |  |  |  |
|  | 1.4.1.4.1.1.4.1.2.1. | **1st Fix** |  |  |  |  |  |  |
|  | 1.4.1.4.1.1.4.1.2.-1 | **2nd Fix** |  |  |  |  |  |  |
|  | 1.4.1.4.1.1.4.1.2.-2 | **PLM_Final Fix** |  |  |  |  |  |  |
|  | 1.4.1.4.1.1.4.1.3 | **ELECTRICAL / CONTROLS** |  |  |  |  |  |  |
|  | 1.4.1.4.1.1.4.1.3.1. | **1st Fix** |  |  |  |  |  |  |
|  | 1.4.1.4.1.1.4.1.3.-1 | **2nd Fix** |  |  |  |  |  |  |
|  | 1.4.1.4.1.1.4.1.3.-2 | **Elec._Final Fix** |  |  |  |  |  |  |

| WBS | Activity |
| --- | --- |
| 1.4.1.4.1.1.4.1.4 | **FIRE FIGHTING SYSTEM** |
| 1.4.1.4.1.1.4.1.4.1. | **1st Fix** |
| 1.4.1.4.1.1.4.1.4.-1 | **2nd Fix** |
| 1.4.1.4.1.1.4.1.4.-2 | **FF_Final Fix** |
| 1 | **B07 - UNDER PLATFORM ZONE 02** |
| 1.4.1.4.1.1.4.1.1 | **HVAC SYSTEM** |
| 1.4.1.4.1.1.4.1.1.1. | **1st Fix** |
| 1.4.1.4.1.1.4.1.1.-1 | **2nd Fix** |
| 1.4.1.4.1.1.4.1.1.-2 | **HVAC_Final Fix** |
| 1.4.1.4.1.1.4.1.2 | **PLUMBING SYSTEM** |
| 1.4.1.4.1.1.4.1.2.1. | **1st Fix** |
| 1.4.1.4.1.1.4.1.2.-1 | **2nd Fix** |
| 1.4.1.4.1.1.4.1.2.-2 | **PLM_Final Fix** |
| 1.4.1.4.1.1.4.1.3 | **ELECTRICAL / CONTROLS** |
| 1.4.1.4.1.1.4.1.3.1. | **1st Fix** |
| 1.4.1.4.1.1.4.1.3.-1 | **2nd Fix** |
| 1.4.1.4.1.1.4.1.3.-2 | **Elec._Final Fix** |
| 1.4.1.4.1.1.4.1.4 | **FIRE FIGHTING SYSTEM** |
| 1.4.1.4.1.1.4.1.4.1. | **1st Fix** |
| 1.4.1.4.1.1.4.1.4.-1 | **2nd Fix** |
| 1.4.1.4.1.1.4.1.4.-2 | **FF_Final Fix** |
| 3 | **B07 - UNDER PLATFORM ZONE 03** |
| 1.4.1.4.1.1.4.1.1 | **HVAC SYSTEM** |
| 1.4.1.4.1.1.4.1.1.1. | **1st Fix** |
| 1.4.1.4.1.1.4.1.1.-1 | **2nd Fix** |
| 1.4.1.4.1.1.4.1.1.-2 | **HVAC_Final Fix** |
| 1.4.1.4.1.1.4.1.2 | **PLUMBING SYSTEM** |
| 1.4.1.4.1.1.4.1.2.1. | **1st Fix** |
| 1.4.1.4.1.1.4.1.2.-1 | **2nd Fix** |
| 1.4.1.4.1.1.4.1.2.-2 | **PLM_Final Fix** |
| 1.4.1.4.1.1.4.1.3 | **ELECTRICAL / CONTROLS** |
| 1.4.1.4.1.1.4.1.3.1. | **1st Fix** |
| 1.4.1.4.1.1.4.1.3.-1 | **2nd Fix** |
| 1.4.1.4.1.1.4.1.3.-2 | **Elec._Final Fix** |
| 1.4.1.4.1.1.4.1.4 | **FIRE FIGHTING SYSTEM** |
| 1.4.1.4.1.1.4.1.4.1. | **1st Fix** |
| 1.4.1.4.1.1.4.1.4.-1 | **2nd Fix** |
| 1.4.1.4.1.1.4.1.4.-2 | **FF_Final Fix** |
| 4 | **B07 - UNDER PLATFORM ZONE 04** |
| 1.4.1.4.1.1.4.1.1 | **HVAC SYSTEM** |
| 1.4.1.4.1.1.4.1.1.1. | **1st Fix** |
| 1.4.1.4.1.1.4.1.1.-1 | **2nd Fix** |
| 1.4.1.4.1.1.4.1.1.-2 | **HVAC_Final Fix** |
| 1.4.1.4.1.1.4.1.2 | **PLUMBING SYSTEM** |
| 1.4.1.4.1.1.4.1.2.1. | **1st Fix** |
| 1.4.1.4.1.1.4.1.2.-1 | **2nd Fix** |
| 1.4.1.4.1.1.4.1.2.-2 | **PLM_Final Fix** |
| 1.4.1.4.1.1.4.1.3 | **ELECTRICAL / CONTROLS** |
| 1.4.1.4.1.1.4.1.3.1. | **1st Fix** |
| 1.4.1.4.1.1.4.1.3.-1 | **2nd Fix** |
| 1.4.1.4.1.1.4.1.3.-2 | **Elec._Final Fix** |
| 1.4.1.4.1.1.4.1.4 | **FIRE FIGHTING SYSTEM** |
| 1.4.1.4.1.1.4.1.4.1. | **1st Fix** |
| 1.4.1.4.1.1.4.1.4.-1 | **2nd Fix** |
| 1.4.1.4.1.1.4.1.4.-2 | **FF_Final Fix** |
| 1.4.2 | **P06 - PLATFORM** |
| 6 | **SOUTH PLATFORM - SIEMENS ROOM ZONE 4 AND 5** |
| 1 | **P06 - PLATFORM - SIEMENS ROOM ZONE 04** |
| 1.4.1.4.1.1.4.1.1 | **HVAC SYSTEM** |
| 1.4.1.4.1.1.4.1.1.1. | **1st Fix** |
| 1.4.1.4.1.1.4.1.1.-1 | **2nd Fix** |
| 1.4.1.4.1.1.4.1.1.-2 | **HVAC_Final Fix** |
| 1.4.1.4.1.1.4.1.2 | **PLUMBING SYSTEM** |
| 1.4.1.4.1.1.4.1.2.1. | **1st Fix** |
| 1.4.1.4.1.1.4.1.2.-1 | **2nd Fix** |
| 1.4.1.4.1.1.4.1.2.-2 | **PLM_Final Fix** |
| 1.4.1.4.1.1.4.1.3 | **ELECTRICAL / CONTROLS** |
| 1.4.1.4.1.1.4.1.3.1. | **1st Fix** |
| 1.4.1.4.1.1.4.1.3.-1 | **2nd Fix** |
| 1.4.1.4.1.1.4.1.3.-2 | **Elec._Final Fix** |

| WBS | Activity |
| --- | --- |
| 1.4.1.4.1.1.4.1.4 | **FIRE FIGHTING SYSTEM** |
| 1.4.1.4.1.1.4.1.4.1. | **1st Fix** |
| 1.4.1.4.1.1.4.1.4.-1 | **2nd Fix** |
| 1.4.1.4.1.1.4.1.4.-2 | **FF_Final Fix** |
| 2 | **P06 - PLATFORM - SIEMENS ROOM ZONE 05** |
| 1.4.1.4.1.1.4.1.1 | **HVAC SYSTEM** |
| 1.4.1.4.1.1.4.1.1.1. | **1st Fix** |
| 1.4.1.4.1.1.4.1.1.-1 | **2nd Fix** |
| 1.4.1.4.1.1.4.1.1.-2 | **HVAC_Final Fix** |
| 1.4.1.4.1.1.4.1.2 | **PLUMBING SYSTEM** |
| 1.4.1.4.1.1.4.1.2.1. | **1st Fix** |
| 1.4.1.4.1.1.4.1.2.-1 | **2nd Fix** |
| 1.4.1.4.1.1.4.1.2.-2 | **PLM_Final Fix** |
| 1.4.1.4.1.1.4.1.3 | **ELECTRICAL / CONTROLS** |
| 1.4.1.4.1.1.4.1.3.1. | **1st Fix** |
| 1.4.1.4.1.1.4.1.3.-1 | **2nd Fix** |
| 1.4.1.4.1.1.4.1.3.-2 | **Elec._Final Fix** |
| 1.4.1.4.1.1.4.1.4 | **FIRE FIGHTING SYSTEM** |
| 1.4.1.4.1.1.4.1.4.1. | **1st Fix** |
| 1.4.1.4.1.1.4.1.4.-1 | **2nd Fix** |
| 1.4.1.4.1.1.4.1.4.-2 | **FF_Final Fix** |
| 3 | **P06 - PLATFORM OUTSIDE SIEMENS ROOM ZONE 4 & 5** |
| 1.4.1.4.1.1.4.1.1 | **HVAC SYSTEM** |
| 1.4.1.4.1.1.4.1.1.1. | **1st Fix** |
| 1.4.1.4.1.1.4.1.1.-1 | **2nd Fix** |
| 1.4.1.4.1.1.4.1.1.-2 | **HVAC_Final Fix** |
| 1.4.1.4.1.1.4.1.2 | **PLUMBING SYSTEM** |
| 1.4.1.4.1.1.4.1.2.1. | **1st Fix** |
| 1.4.1.4.1.1.4.1.2.-1 | **2nd Fix** |
| 1.4.1.4.1.1.4.1.2.-2 | **PLM_Final Fix** |
| 1.4.1.4.1.1.4.1.3 | **ELECTRICAL / CONTROLS** |
| 1.4.1.4.1.1.4.1.3.1. | **1st Fix** |
| 1.4.1.4.1.1.4.1.3.-1 | **2nd Fix** |
| 1.4.1.4.1.1.4.1.3.-2 | **Elec._Final Fix** |
| 1.4.1.4.1.1.4.1.4 | **FIRE FIGHTING SYSTEM** |
| 1.4.1.4.1.1.4.1.4.1. | **1st Fix** |
| 1.4.1.4.1.1.4.1.4.-1 | **2nd Fix** |
| 1.4.1.4.1.1.4.1.4.-2 | **FF_Final Fix** |
| 1 | **CENTRAL PLATFORM - SIEMENS ROOM ZONE 03** |
| 3 | **P06 - PLATFORM - SIEMENS ROOM ZONE 03** |
| 1.4.1.4.1.1.4.1.1 | **HVAC SYSTEM** |
| 1.4.1.4.1.1.4.1.1.1. | **1st Fix** |
| 1.4.1.4.1.1.4.1.1.-1 | **2nd Fix** |
| 1.4.1.4.1.1.4.1.1.-2 | **HVAC_Final Fix** |
| 1.4.1.4.1.1.4.1.2 | **PLUMBING SYSTEM** |
| 1.4.1.4.1.1.4.1.2.1. | **1st Fix** |
| 1.4.1.4.1.1.4.1.2.-1 | **2nd Fix** |
| 1.4.1.4.1.1.4.1.2.-2 | **PLM_Final Fix** |
| 1.4.1.4.1.1.4.1.3 | **ELECTRICAL / CONTROLS** |
| 1.4.1.4.1.1.4.1.3.1. | **1st Fix** |
| 1.4.1.4.1.1.4.1.3.-1 | **2nd Fix** |
| 1.4.1.4.1.1.4.1.3.-2 | **Elec._Final Fix** |
| 1.4.1.4.1.1.4.1.4 | **FIRE FIGHTING SYSTEM** |
| 1.4.1.4.1.1.4.1.4.1. | **1st Fix** |
| 1.4.1.4.1.1.4.1.4.-1 | **2nd Fix** |
| 1.4.1.4.1.1.4.1.4.-2 | **FF_Final Fix** |
| 1 | **P06 - PLATFORM OUTSIDE SIEMENS ROOM ZONE 03** |
| 1.4.1.4.1.1.4.1.1 | **HVAC SYSTEM** |
| 1.4.1.4.1.1.4.1.1.1. | **1st Fix** |
| 1.4.1.4.1.1.4.1.1.-1 | **2nd Fix** |
| 1.4.1.4.1.1.4.1.1.-2 | **HVAC_Final Fix** |
| 1.4.1.4.1.1.4.1.2 | **PLUMBING SYSTEM** |
| 1.4.1.4.1.1.4.1.2.1. | **1st Fix** |
| 1.4.1.4.1.1.4.1.2.-1 | **2nd Fix** |
| 1.4.1.4.1.1.4.1.2.-2 | **PLM_Final Fix** |
| 1.4.1.4.1.1.4.1.3 | **ELECTRICAL / CONTROLS** |
| 1.4.1.4.1.1.4.1.3.1. | **1st Fix** |
| 1.4.1.4.1.1.4.1.3.-1 | **2nd Fix** |
| 1.4.1.4.1.1.4.1.3.-2 | **Elec._Final Fix** |
| 1.4.1.4.1.1.4.1.4 | **FIRE FIGHTING SYSTEM** |

| WBS | Activity |
| --- | --- |
| 1.4.1.4.1.1.4.1.4.1. | **1st Fix** |
| 1.4.1.4.1.1.4.1.4.-1 | **2nd Fix** |
| 1.4.1.4.1.1.4.1.4.-2 | **FF_Final Fix** |
| 2 | **NORTH PLATFORM - SIEMENS ROOM ZONE 01 AND 02** |
| 4 | **P06 - PLATFORM - SIEMENS ROOM ZONE 01** |
| 1.4.1.4.1.1.4.1.1 | **HVAC SYSTEM** |
| 1.4.1.4.1.1.4.1.1.1. | **1st Fix** |
| 1.4.1.4.1.1.4.1.1.-1 | **2nd Fix** |
| 1.4.1.4.1.1.4.1.1.-2 | **HVAC_Final Fix** |
| 1.4.1.4.1.1.4.1.2 | **PLUMBING SYSTEM** |
| 1.4.1.4.1.1.4.1.2.1. | **1st Fix** |
| 1.4.1.4.1.1.4.1.2.-1 | **2nd Fix** |
| 1.4.1.4.1.1.4.1.2.-2 | **PLM_Final Fix** |
| 1.4.1.4.1.1.4.1.3 | **ELECTRICAL / CONTROLS** |
| 1.4.1.4.1.1.4.1.3.1. | **1st Fix** |
| 1.4.1.4.1.1.4.1.3.-1 | **2nd Fix** |
| 1.4.1.4.1.1.4.1.3.-2 | **Elec._Final Fix** |
| 1.4.1.4.1.1.4.1.4 | **FIRE FIGHTING SYSTEM** |
| 1.4.1.4.1.1.4.1.4.1. | **1st Fix** |
| 1.4.1.4.1.1.4.1.4.-1 | **2nd Fix** |
| 1.4.1.4.1.1.4.1.4.-2 | **FF_Final Fix** |
| 5 | **P06 - PLATFORM - SIEMENS ROOM ZONE 02** |
| 1.4.1.4.1.1.4.1.1 | **HVAC SYSTEM** |
| 1.4.1.4.1.1.4.1.1.1. | **1st Fix** |
| 1.4.1.4.1.1.4.1.1.-1 | **2nd Fix** |
| 1.4.1.4.1.1.4.1.1.-2 | **HVAC_Final Fix** |
| 1.4.1.4.1.1.4.1.2 | **PLUMBING SYSTEM** |
| 1.4.1.4.1.1.4.1.2.1. | **1st Fix** |
| 1.4.1.4.1.1.4.1.2.-1 | **2nd Fix** |
| 1.4.1.4.1.1.4.1.2.-2 | **PLM_Final Fix** |
| 1.4.1.4.1.1.4.1.3 | **ELECTRICAL / CONTROLS** |
| 1.4.1.4.1.1.4.1.3.1. | **1st Fix** |
| 1.4.1.4.1.1.4.1.3.-1 | **2nd Fix** |
| 1.4.1.4.1.1.4.1.3.-2 | **Elec._Final Fix** |
| 1.4.1.4.1.1.4.1.4 | **FIRE FIGHTING SYSTEM** |
| 1.4.1.4.1.1.4.1.4.1. | **1st Fix** |
| 1.4.1.4.1.1.4.1.4.-1 | **2nd Fix** |
| 1.4.1.4.1.1.4.1.4.-2 | **FF_Final Fix** |
| 1 | **P06 - PLATFORM OUTSIDE SIEMENS ROOM ZONE 1 & 2** |
| 1.4.1.4.1.1.4.1.1 | **HVAC SYSTEM** |
| 1.4.1.4.1.1.4.1.1.1. | **1st Fix** |
| 1.4.1.4.1.1.4.1.1.-1 | **2nd Fix** |
| 1.4.1.4.1.1.4.1.1.-2 | **HVAC_Final Fix** |
| 1.4.1.4.1.1.4.1.2 | **PLUMBING SYSTEM** |
| 1.4.1.4.1.1.4.1.2.1. | **1st Fix** |
| 1.4.1.4.1.1.4.1.2.-1 | **2nd Fix** |
| 1.4.1.4.1.1.4.1.2.-2 | **PLM_Final Fix** |
| 1.4.1.4.1.1.4.1.3 | **ELECTRICAL / CONTROLS** |
| 1.4.1.4.1.1.4.1.3.1. | **1st Fix** |
| 1.4.1.4.1.1.4.1.3.-1 | **2nd Fix** |
| 1.4.1.4.1.1.4.1.3.-2 | **Elec._Final Fix** |
| 1.4.1.4.1.1.4.1.4 | **FIRE FIGHTING SYSTEM** |
| 1.4.1.4.1.1.4.1.4.1. | **1st Fix** |
| 1.4.1.4.1.1.4.1.4.-1 | **2nd Fix** |
| 1.4.1.4.1.1.4.1.4.-2 | **FF_Final Fix** |
| 1.4.32 | **B05 - MEZZAINE** |
| 7 | **SOUTH MEZZAINE - ZONE 4 AND 5** |
| 1 | **B05 - MEZZAINE ZONE 04** |
| 1.4.1.4.1.1.4.1.1 | **HVAC SYSTEM** |
| 1.4.1.4.1.1.4.1.1.1. | **1st Fix** |
| 1.4.1.4.1.1.4.1.1.-1 | **2nd Fix** |
| 1.4.1.4.1.1.4.1.1.-2 | **HVAC_Final Fix** |
| 1.4.1.4.1.1.4.1.2 | **PLUMBING SYSTEM** |
| 1.4.1.4.1.1.4.1.2.1. | **1st Fix** |
| 1.4.1.4.1.1.4.1.2.-1 | **2nd Fix** |
| 1.4.1.4.1.1.4.1.2.-2 | **PLM_Final Fix** |
| 1.4.1.4.1.1.4.1.3 | **ELECTRICAL / CONTROLS** |
| 1.4.1.4.1.1.4.1.3.1. | **1st Fix** |
| 1.4.1.4.1.1.4.1.3.-1 | **2nd Fix** |
| 1.4.1.4.1.1.4.1.3.-2 | **Elec._Final Fix** |

| WBS | Activity |
| --- | --- |
| 1.4.1.4.1.1.4.1.4 | **FIRE FIGHTING SYSTEM** |
| 1.4.1.4.1.1.4.1.4.1. | **1st Fix** |
| 1.4.1.4.1.1.4.1.4.-1 | **2nd Fix** |
| 1.4.1.4.1.1.4.1.4.-2 | **FF_Final Fix** |
| 2 | **B05 - MEZZAINE ZONE 05** |
| 1.4.1.4.1.1.4.1.1 | **HVAC SYSTEM** |
| 1.4.1.4.1.1.4.1.1.1. | **1st Fix** |
| 1.4.1.4.1.1.4.1.1.-1 | **2nd Fix** |
| 1.4.1.4.1.1.4.1.1.-2 | **HVAC_Final Fix** |
| 1.4.1.4.1.1.4.1.2 | **PLUMBING SYSTEM** |
| 1.4.1.4.1.1.4.1.2.1. | **1st Fix** |
| 1.4.1.4.1.1.4.1.2.-1 | **2nd Fix** |
| 1.4.1.4.1.1.4.1.2.-2 | **PLM_Final Fix** |
| 1.4.1.4.1.1.4.1.3 | **ELECTRICAL / CONTROLS** |
| 1.4.1.4.1.1.4.1.3.1. | **1st Fix** |
| 1.4.1.4.1.1.4.1.3.-1 | **2nd Fix** |
| 1.4.1.4.1.1.4.1.3.-2 | **Elec._Final Fix** |
| 1.4.1.4.1.1.4.1.4 | **FIRE FIGHTING SYSTEM** |
| 1.4.1.4.1.1.4.1.4.1. | **1st Fix** |
| 1.4.1.4.1.1.4.1.4.-1 | **2nd Fix** |
| 1.4.1.4.1.1.4.1.4.-2 | **FF_Final Fix** |
| 6 | **CENTRAL MEZZAINE - ZONE 03** |
| 3 | **B05 - MEZZAINE ZONE 03** |
| 1.4.1.4.1.1.4.1.1 | **HVAC SYSTEM** |
| 1.4.1.4.1.1.4.1.1.1. | **1st Fix** |
| 1.4.1.4.1.1.4.1.1.-1 | **2nd Fix** |
| 1.4.1.4.1.1.4.1.1.-2 | **HVAC_Final Fix** |
| 1.4.1.4.1.1.4.1.2 | **PLUMBING SYSTEM** |
| 1.4.1.4.1.1.4.1.2.1. | **1st Fix** |
| 1.4.1.4.1.1.4.1.2.-1 | **2nd Fix** |
| 1.4.1.4.1.1.4.1.2.-2 | **PLM_Final Fix** |
| 1.4.1.4.1.1.4.1.3 | **ELECTRICAL / CONTROLS** |
| 1.4.1.4.1.1.4.1.3.1. | **1st Fix** |
| 1.4.1.4.1.1.4.1.3.-1 | **2nd Fix** |
| 1.4.1.4.1.1.4.1.3.-2 | **Elec._Final Fix** |
| 1.4.1.4.1.1.4.1.4 | **FIRE FIGHTING SYSTEM** |
| 1.4.1.4.1.1.4.1.4.1. | **1st Fix** |
| 1.4.1.4.1.1.4.1.4.-1 | **2nd Fix** |
| 1.4.1.4.1.1.4.1.4.-2 | **FF_Final Fix** |
| 1 | **NORTH MEZZAINE - ZONE 01 AND 02** |
| 4 | **B05 - MEZZAINE ZONE 01** |
| 1.4.1.4.1.1.4.1.1 | **HVAC SYSTEM** |
| 1.4.1.4.1.1.4.1.1.1. | **1st Fix** |
| 1.4.1.4.1.1.4.1.1.-1 | **2nd Fix** |
| 1.4.1.4.1.1.4.1.1.-2 | **HVAC_Final Fix** |
| 1.4.1.4.1.1.4.1.2 | **PLUMBING SYSTEM** |
| 1.4.1.4.1.1.4.1.2.1. | **1st Fix** |
| 1.4.1.4.1.1.4.1.2.-1 | **2nd Fix** |
| 1.4.1.4.1.1.4.1.2.-2 | **PLM_Final Fix** |
| 1.4.1.4.1.1.4.1.3 | **ELECTRICAL / CONTROLS** |
| 1.4.1.4.1.1.4.1.3.1. | **1st Fix** |
| 1.4.1.4.1.1.4.1.3.-1 | **2nd Fix** |
| 1.4.1.4.1.1.4.1.3.-2 | **Elec._Final Fix** |
| 1.4.1.4.1.1.4.1.4 | **FIRE FIGHTING SYSTEM** |
| 1.4.1.4.1.1.4.1.4.1. | **1st Fix** |
| 1.4.1.4.1.1.4.1.4.-1 | **2nd Fix** |
| 1.4.1.4.1.1.4.1.4.-2 | **FF_Final Fix** |
| 5 | **B05 - MEZZAINE ZONE 02** |
| 1.4.1.4.1.1.4.1.1 | **HVAC SYSTEM** |
| 1.4.1.4.1.1.4.1.1.1. | **1st Fix** |
| 1.4.1.4.1.1.4.1.1.-1 | **2nd Fix** |
| 1.4.1.4.1.1.4.1.1.-2 | **HVAC_Final Fix** |
| 1.4.1.4.1.1.4.1.2 | **PLUMBING SYSTEM** |
| 1.4.1.4.1.1.4.1.2.1. | **1st Fix** |
| 1.4.1.4.1.1.4.1.2.-1 | **2nd Fix** |
| 1.4.1.4.1.1.4.1.2.-2 | **PLM_Final Fix** |
| 1.4.1.4.1.1.4.1.3 | **ELECTRICAL / CONTROLS** |
| 1.4.1.4.1.1.4.1.3.1. | **1st Fix** |
| 1.4.1.4.1.1.4.1.3.-1 | **2nd Fix** |
| 1.4.1.4.1.1.4.1.3.-2 | **Elec._Final Fix** |

| WBS | Activity |
| --- | --- |
| 1.4.1.4.1.1.4.1.4 | **FIRE FIGHTING SYSTEM** |
| 1.4.1.4.1.1.4.1.4.1. | **1st Fix** |
| 1.4.1.4.1.1.4.1.4.-1 | **2nd Fix** |
| 1.4.1.4.1.1.4.1.4.-2 | **FF_Final Fix** |
| 1.4.3 | **B04 - TECHINICAL** |
| 7 | **SOUTH TECHINICAL - ZONE 4 AND 5** |
| 1 | **B04 - TECHINICAL ZONE 04** |
| 1.4.1.4.1.1.4.1.1 | **HVAC SYSTEM** |
| 1.4.1.4.1.1.4.1.1.1. | **1st Fix** |
| 1.4.1.4.1.1.4.1.1.-1 | **2nd Fix** |
| 1.4.1.4.1.1.4.1.1.-2 | **HVAC_Final Fix** |
| 1.4.1.4.1.1.4.1.2 | **PLUMBING SYSTEM** |
| 1.4.1.4.1.1.4.1.2.1. | **1st Fix** |
| 1.4.1.4.1.1.4.1.2.-1 | **2nd Fix** |
| 1.4.1.4.1.1.4.1.2.-2 | **PLM_Final Fix** |
| 1.4.1.4.1.1.4.1.3 | **ELECTRICAL / CONTROLS** |
| 1.4.1.4.1.1.4.1.3.1. | **1st Fix** |
| 1.4.1.4.1.1.4.1.3.-1 | **2nd Fix** |
| 1.4.1.4.1.1.4.1.3.-2 | **Elec._Final Fix** |
| 1.4.1.4.1.1.4.1.4 | **FIRE FIGHTING SYSTEM** |
| 1.4.1.4.1.1.4.1.4.1. | **1st Fix** |
| 1.4.1.4.1.1.4.1.4.-1 | **2nd Fix** |
| 1.4.1.4.1.1.4.1.4.-2 | **FF_Final Fix** |
| 2 | **B04 - TECHINICAL ZONE 05** |
| 1.4.1.4.1.1.4.1.1 | **HVAC SYSTEM** |
| 1.4.1.4.1.1.4.1.1.1. | **1st Fix** |
| 1.4.1.4.1.1.4.1.1.-1 | **2nd Fix** |
| 1.4.1.4.1.1.4.1.1.-2 | **HVAC_Final Fix** |
| 1.4.1.4.1.1.4.1.2 | **PLUMBING SYSTEM** |
| 1.4.1.4.1.1.4.1.2.1. | **1st Fix** |
| 1.4.1.4.1.1.4.1.2.-1 | **2nd Fix** |
| 1.4.1.4.1.1.4.1.2.-2 | **PLM_Final Fix** |
| 1.4.1.4.1.1.4.1.3 | **ELECTRICAL / CONTROLS** |
| 1.4.1.4.1.1.4.1.3.1. | **1st Fix** |
| 1.4.1.4.1.1.4.1.3.-1 | **2nd Fix** |
| 1.4.1.4.1.1.4.1.3.-2 | **Elec._Final Fix** |
| 1.4.1.4.1.1.4.1.4 | **FIRE FIGHTING SYSTEM** |
| 1.4.1.4.1.1.4.1.4.1. | **1st Fix** |
| 1.4.1.4.1.1.4.1.4.-1 | **2nd Fix** |
| 1.4.1.4.1.1.4.1.4.-2 | **FF_Final Fix** |
| 6 | **CENTRAL TECHINICAL - ZONE 03** |
| 3 | **B04 - TECHINICAL ZONE 03** |
| 1.4.1.4.1.1.4.1.1 | **HVAC SYSTEM** |
| 1.4.1.4.1.1.4.1.1.1. | **1st Fix** |
| 1.4.1.4.1.1.4.1.1.-1 | **2nd Fix** |
| 1.4.1.4.1.1.4.1.1.-2 | **HVAC_Final Fix** |
| 1.4.1.4.1.1.4.1.2 | **PLUMBING SYSTEM** |
| 1.4.1.4.1.1.4.1.2.1. | **1st Fix** |
| 1.4.1.4.1.1.4.1.2.-1 | **2nd Fix** |
| 1.4.1.4.1.1.4.1.2.-2 | **PLM_Final Fix** |
| 1.4.1.4.1.1.4.1.3 | **ELECTRICAL / CONTROLS** |
| 1.4.1.4.1.1.4.1.3.1. | **1st Fix** |
| 1.4.1.4.1.1.4.1.3.-1 | **2nd Fix** |
| 1.4.1.4.1.1.4.1.3.-2 | **Elec._Final Fix** |
| 1.4.1.4.1.1.4.1.4 | **FIRE FIGHTING SYSTEM** |
| 1.4.1.4.1.1.4.1.4.1. | **1st Fix** |
| 1.4.1.4.1.1.4.1.4.-1 | **2nd Fix** |
| 1.4.1.4.1.1.4.1.4.-2 | **FF_Final Fix** |
| 1 | **NORTH TECHINICAL - ZONE 01 AND 02** |
| 4 | **B04 - TECHINICAL ZONE 01** |
| 1.4.1.4.1.1.4.1.1 | **HVAC SYSTEM** |
| 1.4.1.4.1.1.4.1.1.1. | **1st Fix** |
| 1.4.1.4.1.1.4.1.1.-1 | **2nd Fix** |
| 1.4.1.4.1.1.4.1.1.-2 | **HVAC_Final Fix** |
| 1.4.1.4.1.1.4.1.2 | **PLUMBING SYSTEM** |
| 1.4.1.4.1.1.4.1.2.1. | **1st Fix** |
| 1.4.1.4.1.1.4.1.2.-1 | **2nd Fix** |
| 1.4.1.4.1.1.4.1.2.-2 | **PLM_Final Fix** |
| 1.4.1.4.1.1.4.1.3 | **ELECTRICAL / CONTROLS** |
| 1.4.1.4.1.1.4.1.3.1. | **1st Fix** |

| WBS | Activity |
| --- | --- |
| 1.4.1.4.1.1.4.1.3.-1 | **2nd Fix** |
| 1.4.1.4.1.1.4.1.3.-2 | **Elec._Final Fix** |
| 1.4.1.4.1.1.4.1.4 | **FIRE FIGHTING SYSTEM** |
| 1.4.1.4.1.1.4.1.4.1. | **1st Fix** |
| 1.4.1.4.1.1.4.1.4.-1 | **2nd Fix** |
| 1.4.1.4.1.1.4.1.4.-2 | **FF_Final Fix** |
| 5 | **B04 - TECHINICAL ZONE 02** |
| 1.4.1.4.1.1.4.1.1 | **HVAC SYSTEM** |
| 1.4.1.4.1.1.4.1.1.1. | **1st Fix** |
| 1.4.1.4.1.1.4.1.1.-1 | **2nd Fix** |
| 1.4.1.4.1.1.4.1.1.-2 | **HVAC_Final Fix** |
| 1.4.1.4.1.1.4.1.2 | **PLUMBING SYSTEM** |
| 1.4.1.4.1.1.4.1.2.1. | **1st Fix** |
| 1.4.1.4.1.1.4.1.2.-1 | **2nd Fix** |
| 1.4.1.4.1.1.4.1.2.-2 | **PLM_Final Fix** |
| 1.4.1.4.1.1.4.1.3 | **ELECTRICAL / CONTROLS** |
| 1.4.1.4.1.1.4.1.3.1. | **1st Fix** |
| 1.4.1.4.1.1.4.1.3.-1 | **2nd Fix** |
| 1.4.1.4.1.1.4.1.3.-2 | **Elec._Final Fix** |
| 1.4.1.4.1.1.4.1.4 | **FIRE FIGHTING SYSTEM** |
| 1.4.1.4.1.1.4.1.4.1. | **1st Fix** |
| 1.4.1.4.1.1.4.1.4.-1 | **2nd Fix** |
| 1.4.1.4.1.1.4.1.4.-2 | **FF_Final Fix** |
| 1.4.31 | **B03 - CONCOURSE** |
| 7 | **SOUTH CONCOURSE - ZONE 4 AND 5** |
| 1 | **B03 - CONCOURSE ZONE 04** |
| 1.4.1.4.1.1.4.1.1 | **HVAC SYSTEM** |
| 1.4.1.4.1.1.4.1.1.1. | **1st Fix** |
| 1.4.1.4.1.1.4.1.1.-1 | **2nd Fix** |
| 1.4.1.4.1.1.4.1.1.-2 | **HVAC_Final Fix** |
| 1.4.1.4.1.1.4.1.2 | **PLUMBING SYSTEM** |
| 1.4.1.4.1.1.4.1.2.1. | **1st Fix** |
| 1.4.1.4.1.1.4.1.2.-1 | **2nd Fix** |
| 1.4.1.4.1.1.4.1.2.-2 | **PLM_Final Fix** |
| 1.4.1.4.1.1.4.1.3 | **ELECTRICAL / CONTROLS** |
| 1.4.1.4.1.1.4.1.3.1. | **1st Fix** |
| 1.4.1.4.1.1.4.1.3.-1 | **2nd Fix** |
| 1.4.1.4.1.1.4.1.3.-2 | **Elec._Final Fix** |
| 1.4.1.4.1.1.4.1.4 | **FIRE FIGHTING SYSTEM** |
| 1.4.1.4.1.1.4.1.4.1. | **1st Fix** |
| 1.4.1.4.1.1.4.1.4.-1 | **2nd Fix** |
| 1.4.1.4.1.1.4.1.4.-2 | **FF_Final Fix** |
| 2 | **B03 - CONCOURSE ZONE 05** |
| 1.4.1.4.1.1.4.1.1 | **HVAC SYSTEM** |
| 1.4.1.4.1.1.4.1.1.1. | **1st Fix** |
| 1.4.1.4.1.1.4.1.1.-1 | **2nd Fix** |
| 1.4.1.4.1.1.4.1.1.-2 | **HVAC_Final Fix** |
| 1.4.1.4.1.1.4.1.2 | **PLUMBING SYSTEM** |
| 1.4.1.4.1.1.4.1.2.1. | **1st Fix** |
| 1.4.1.4.1.1.4.1.2.-1 | **2nd Fix** |
| 1.4.1.4.1.1.4.1.2.-2 | **PLM_Final Fix** |
| 1.4.1.4.1.1.4.1.3 | **ELECTRICAL / CONTROLS** |
| 1.4.1.4.1.1.4.1.3.1. | **1st Fix** |
| 1.4.1.4.1.1.4.1.3.-1 | **2nd Fix** |
| 1.4.1.4.1.1.4.1.3.-2 | **Elec._Final Fix** |
| 1.4.1.4.1.1.4.1.4 | **FIRE FIGHTING SYSTEM** |
| 1.4.1.4.1.1.4.1.4.1. | **1st Fix** |
| 1.4.1.4.1.1.4.1.4.-1 | **2nd Fix** |
| 1.4.1.4.1.1.4.1.4.-2 | **FF_Final Fix** |
| 6 | **CENTRAL CONCOURSE - ZONE 03** |
| 3 | **B03 - CONCOURSEZONE 03** |
| 1.4.1.4.1.1.4.1.1 | **HVAC SYSTEM** |
| 1.4.1.4.1.1.4.1.1.1. | **1st Fix** |
| 1.4.1.4.1.1.4.1.1.-1 | **2nd Fix** |
| 1.4.1.4.1.1.4.1.1.-2 | **HVAC_Final Fix** |
| 1.4.1.4.1.1.4.1.2 | **PLUMBING SYSTEM** |
| 1.4.1.4.1.1.4.1.2.1. | **1st Fix** |
| 1.4.1.4.1.1.4.1.2.-1 | **2nd Fix** |
| 1.4.1.4.1.1.4.1.2.-2 | **PLM_Final Fix** |
| 1.4.1.4.1.1.4.1.3 | **ELECTRICAL / CONTROLS** |

| WBS | Activity |
| --- | --- |
| 1.4.1.4.1.1.4.1.3.1. | **1st Fix** |
| 1.4.1.4.1.1.4.1.3.-1 | **2nd Fix** |
| 1.4.1.4.1.1.4.1.3.-2 | **Elec._Final Fix** |
| 1.4.1.4.1.1.4.1.4 | **FIRE FIGHTING SYSTEM** |
| 1.4.1.4.1.1.4.1.4.1. | **1st Fix** |
| 1.4.1.4.1.1.4.1.4.-1 | **2nd Fix** |
| 1.4.1.4.1.1.4.1.4.-2 | **FF_Final Fix** |
| 1 | **NORTH CONCOURSE - 01 AND 02** |
| 4 | **B03 - CONCOURSE ZONE 01** |
| 1.4.1.4.1.1.4.1.1 | **HVAC SYSTEM** |
| 1.4.1.4.1.1.4.1.1.1. | **1st Fix** |
| 1.4.1.4.1.1.4.1.1.-1 | **2nd Fix** |
| 1.4.1.4.1.1.4.1.1.-2 | **HVAC_Final Fix** |
| 1.4.1.4.1.1.4.1.2 | **PLUMBING SYSTEM** |
| 1.4.1.4.1.1.4.1.2.1. | **1st Fix** |
| 1.4.1.4.1.1.4.1.2.-1 | **2nd Fix** |
| 1.4.1.4.1.1.4.1.2.-2 | **PLM_Final Fix** |
| 1.4.1.4.1.1.4.1.3 | **ELECTRICAL / CONTROLS** |
| 1.4.1.4.1.1.4.1.3.1. | **1st Fix** |
| 1.4.1.4.1.1.4.1.3.-1 | **2nd Fix** |
| 1.4.1.4.1.1.4.1.3.-2 | **Elec._Final Fix** |
| 1.4.1.4.1.1.4.1.4 | **FIRE FIGHTING SYSTEM** |
| 1.4.1.4.1.1.4.1.4.1. | **1st Fix** |
| 1.4.1.4.1.1.4.1.4.-1 | **2nd Fix** |
| 1.4.1.4.1.1.4.1.4.-2 | **FF_Final Fix** |
| 5 | **B03 - CONCOURSE ZONE 02** |
| 1.4.1.4.1.1.4.1.1 | **HVAC SYSTEM** |
| 1.4.1.4.1.1.4.1.1.1. | **1st Fix** |
| 1.4.1.4.1.1.4.1.1.-1 | **2nd Fix** |
| 1.4.1.4.1.1.4.1.1.-2 | **HVAC_Final Fix** |
| 1.4.1.4.1.1.4.1.2 | **PLUMBING SYSTEM** |
| 1.4.1.4.1.1.4.1.2.1. | **1st Fix** |
| 1.4.1.4.1.1.4.1.2.-1 | **2nd Fix** |
| 1.4.1.4.1.1.4.1.2.-2 | **PLM_Final Fix** |
| 1.4.1.4.1.1.4.1.3 | **ELECTRICAL / CONTROLS** |
| 1.4.1.4.1.1.4.1.3.1. | **1st Fix** |
| 1.4.1.4.1.1.4.1.3.-1 | **2nd Fix** |
| 1.4.1.4.1.1.4.1.3.-2 | **Elec._Final Fix** |
| 1.4.1.4.1.1.4.1.4 | **FIRE FIGHTING SYSTEM** |
| 1.4.1.4.1.1.4.1.4.1. | **1st Fix** |
| 1.4.1.4.1.1.4.1.4.-1 | **2nd Fix** |
| 1.4.1.4.1.1.4.1.4.-2 | **FF_Final Fix** |
| 1.4.311 | **B02 - CONCOURSE MEZZ & TV LOUVER** |
| 7 | **SOUTH CONCOURSE MEZZ & TV LOUVER - ZONE 4 AND 5** |
| 1 | **B02 - CONCOURSE MEZZ & TV LOUVER - ZONE 04** |
| 1.4.1.4.1.1.4.1.1 | **HVAC SYSTEM** |
| 1.4.1.4.1.1.4.1.1.1. | **1st Fix** |
| 1.4.1.4.1.1.4.1.1.-1 | **2nd Fix** |
| 1.4.1.4.1.1.4.1.1.-2 | **HVAC_Final Fix** |
| 1.4.1.4.1.1.4.1.2 | **PLUMBING SYSTEM** |
| 1.4.1.4.1.1.4.1.2.1. | **1st Fix** |
| 1.4.1.4.1.1.4.1.2.-1 | **2nd Fix** |
| 1.4.1.4.1.1.4.1.2.-2 | **PLM_Final Fix** |
| 1.4.1.4.1.1.4.1.3 | **ELECTRICAL / CONTROLS** |
| 1.4.1.4.1.1.4.1.3.1. | **1st Fix** |
| 1.4.1.4.1.1.4.1.3.-1 | **2nd Fix** |
| 1.4.1.4.1.1.4.1.3.-2 | **Elec._Final Fix** |
| 1.4.1.4.1.1.4.1.4 | **FIRE FIGHTING SYSTEM** |
| 1.4.1.4.1.1.4.1.4.1. | **1st Fix** |
| 1.4.1.4.1.1.4.1.4.-1 | **2nd Fix** |
| 1.4.1.4.1.1.4.1.4.-2 | **FF_Final Fix** |
| 2 | **B02 - CONCOURSE MEZZ & TV LOUVER - ZONE 05** |
| 1.4.1.4.1.1.4.1.1 | **HVAC SYSTEM** |
| 1.4.1.4.1.1.4.1.1.1. | **1st Fix** |
| 1.4.1.4.1.1.4.1.1.-1 | **2nd Fix** |
| 1.4.1.4.1.1.4.1.1.-2 | **HVAC_Final Fix** |
| 1.4.1.4.1.1.4.1.2 | **PLUMBING SYSTEM** |
| 1.4.1.4.1.1.4.1.2.1. | **1st Fix** |
| 1.4.1.4.1.1.4.1.2.-1 | **2nd Fix** |
| 1.4.1.4.1.1.4.1.2.-2 | **PLM_Final Fix** |

| WBS | Activity |
| --- | --- |
| 1.4.1.4.1.1.4.1.3 | **ELECTRICAL / CONTROLS** |
| 1.4.1.4.1.1.4.1.3.1. | **1st Fix** |
| 1.4.1.4.1.1.4.1.3.-1 | **2nd Fix** |
| 1.4.1.4.1.1.4.1.3.-2 | **Elec._Final Fix** |
| 1.4.1.4.1.1.4.1.4 | **FIRE FIGHTING SYSTEM** |
| 1.4.1.4.1.1.4.1.4.1. | **1st Fix** |
| 1.4.1.4.1.1.4.1.4.-1 | **2nd Fix** |
| 1.4.1.4.1.1.4.1.4.-2 | **FF_Final Fix** |
| 6 | **CENTRAL CONCOURSE MEZZ & TV LOUVER - ZONE 03** |
| 3 | **B02 - CONCOURSE MEZZ & TV LOUVER - ZONE 03** |
| 1.4.1.4.1.1.4.1.1 | **HVAC SYSTEM** |
| 1.4.1.4.1.1.4.1.1.1. | **1st Fix** |
| 1.4.1.4.1.1.4.1.1.-1 | **2nd Fix** |
| 1.4.1.4.1.1.4.1.1.-2 | **HVAC_Final Fix** |
| 1.4.1.4.1.1.4.1.2 | **PLUMBING SYSTEM** |
| 1.4.1.4.1.1.4.1.2.1. | **1st Fix** |
| 1.4.1.4.1.1.4.1.2.-1 | **2nd Fix** |
| 1.4.1.4.1.1.4.1.2.-2 | **PLM_Final Fix** |
| 1.4.1.4.1.1.4.1.3 | **ELECTRICAL / CONTROLS** |
| 1.4.1.4.1.1.4.1.3.1. | **1st Fix** |
| 1.4.1.4.1.1.4.1.3.-1 | **2nd Fix** |
| 1.4.1.4.1.1.4.1.3.-2 | **Elec._Final Fix** |
| 1.4.1.4.1.1.4.1.4 | **FIRE FIGHTING SYSTEM** |
| 1.4.1.4.1.1.4.1.4.1. | **1st Fix** |
| 1.4.1.4.1.1.4.1.4.-1 | **2nd Fix** |
| 1.4.1.4.1.1.4.1.4.-2 | **FF_Final Fix** |
| 1 | **NORTH CONCOURSE MEZZ & TV LOUVER - ZONE 01 AND 02** |
| 4 | **B02 - CONCOURSE MEZZ & TV LOUVER - ZONE 01** |
| 1.4.1.4.1.1.4.1.1 | **HVAC SYSTEM** |
| 1.4.1.4.1.1.4.1.1.1. | **1st Fix** |
| 1.4.1.4.1.1.4.1.1.-1 | **2nd Fix** |
| 1.4.1.4.1.1.4.1.1.-2 | **HVAC_Final Fix** |
| 1.4.1.4.1.1.4.1.2 | **PLUMBING SYSTEM** |
| 1.4.1.4.1.1.4.1.2.1. | **1st Fix** |
| 1.4.1.4.1.1.4.1.2.-1 | **2nd Fix** |
| 1.4.1.4.1.1.4.1.2.-2 | **PLM_Final Fix** |
| 1.4.1.4.1.1.4.1.3 | **ELECTRICAL / CONTROLS** |
| 1.4.1.4.1.1.4.1.3.1. | **1st Fix** |
| 1.4.1.4.1.1.4.1.3.-1 | **2nd Fix** |
| 1.4.1.4.1.1.4.1.3.-2 | **Elec._Final Fix** |
| 1.4.1.4.1.1.4.1.4 | **FIRE FIGHTING SYSTEM** |
| 1.4.1.4.1.1.4.1.4.1. | **1st Fix** |
| 1.4.1.4.1.1.4.1.4.-1 | **2nd Fix** |
| 1.4.1.4.1.1.4.1.4.-2 | **FF_Final Fix** |
| 5 | **B02 - CONCOURSE MEZZ & TV LOUVER - ZONE 02** |
| 1.4.1.4.1.1.4.1.1 | **HVAC SYSTEM** |
| 1.4.1.4.1.1.4.1.1.1. | **1st Fix** |
| 1.4.1.4.1.1.4.1.1.-1 | **2nd Fix** |
| 1.4.1.4.1.1.4.1.1.-2 | **HVAC_Final Fix** |
| 1.4.1.4.1.1.4.1.2 | **PLUMBING SYSTEM** |
| 1.4.1.4.1.1.4.1.2.1. | **1st Fix** |
| 1.4.1.4.1.1.4.1.2.-1 | **2nd Fix** |
| 1.4.1.4.1.1.4.1.2.-2 | **PLM_Final Fix** |
| 1.4.1.4.1.1.4.1.3 | **ELECTRICAL / CONTROLS** |
| 1.4.1.4.1.1.4.1.3.1. | **1st Fix** |
| 1.4.1.4.1.1.4.1.3.-1 | **2nd Fix** |
| 1.4.1.4.1.1.4.1.3.-2 | **Elec._Final Fix** |
| 1.4.1.4.1.1.4.1.4 | **FIRE FIGHTING SYSTEM** |
| 1.4.1.4.1.1.4.1.4.1. | **1st Fix** |
| 1.4.1.4.1.1.4.1.4.-1 | **2nd Fix** |
| 1.4.1.4.1.1.4.1.4.-2 | **FF_Final Fix** |
| 1.4.312 | **G00 - GROUND** |
| 7 | **SOUTH GROUND -ZONE 4 AND 5** |
| 1 | **G00 - GROUND ZONE 04** |
| 1.4.1.4.1.1.4.1.1 | **HVAC SYSTEM** |
| 1.4.1.4.1.1.4.1.1.1. | **1st Fix** |
| 1.4.1.4.1.1.4.1.1.-1 | **2nd Fix** |
| 1.4.1.4.1.1.4.1.1.-2 | **HVAC_Final Fix** |
| 1.4.1.4.1.1.4.1.2 | **PLUMBING SYSTEM** |
| 1.4.1.4.1.1.4.1.2.1. | **1st Fix** |

| WBS | Activity |
| --- | --- |
| 1.4.1.4.1.1.4.1.2.-1 | **2nd Fix** |
| 1.4.1.4.1.1.4.1.2.-2 | **PLM_Final Fix** |
| 1.4.1.4.1.1.4.1.3 | **ELECTRICAL / CONTROLS** |
| 1.4.1.4.1.1.4.1.3.1. | **1st Fix** |
| 1.4.1.4.1.1.4.1.3.-1 | **2nd Fix** |
| 1.4.1.4.1.1.4.1.3.-2 | **Elec._Final Fix** |
| 1.4.1.4.1.1.4.1.4 | **FIRE FIGHTING SYSTEM** |
| 1.4.1.4.1.1.4.1.4.1. | **1st Fix** |
| 1.4.1.4.1.1.4.1.4.-1 | **2nd Fix** |
| 1.4.1.4.1.1.4.1.4.-2 | **FF_Final Fix** |
| 2 | **G00 - GROUND ZONE 05** |
| 1.4.1.4.1.1.4.1.1 | **HVAC SYSTEM** |
| 1.4.1.4.1.1.4.1.1.1. | **1st Fix** |
| 1.4.1.4.1.1.4.1.1.-1 | **2nd Fix** |
| 1.4.1.4.1.1.4.1.1.-2 | **HVAC_Final Fix** |
| 1.4.1.4.1.1.4.1.2 | **PLUMBING SYSTEM** |
| 1.4.1.4.1.1.4.1.2.1. | **1st Fix** |
| 1.4.1.4.1.1.4.1.2.-1 | **2nd Fix** |
| 1.4.1.4.1.1.4.1.2.-2 | **PLM_Final Fix** |
| 1.4.1.4.1.1.4.1.3 | **ELECTRICAL / CONTROLS** |
| 1.4.1.4.1.1.4.1.3.1. | **1st Fix** |
| 1.4.1.4.1.1.4.1.3.-1 | **2nd Fix** |
| 1.4.1.4.1.1.4.1.3.-2 | **Elec._Final Fix** |
| 1.4.1.4.1.1.4.1.4 | **FIRE FIGHTING SYSTEM** |
| 1.4.1.4.1.1.4.1.4.1. | **1st Fix** |
| 1.4.1.4.1.1.4.1.4.-1 | **2nd Fix** |
| 1.4.1.4.1.1.4.1.4.-2 | **FF_Final Fix** |
| 6 | **CENTRAL GROUND - ZONE 03** |
| 3 | **G00 - GROUND ZONE 03** |
| 1.4.1.4.1.1.4.1.1 | **HVAC SYSTEM** |
| 1.4.1.4.1.1.4.1.1.1. | **1st Fix** |
| 1.4.1.4.1.1.4.1.1.-1 | **2nd Fix** |
| 1.4.1.4.1.1.4.1.1.-2 | **HVAC_Final Fix** |
| 1.4.1.4.1.1.4.1.2 | **PLUMBING SYSTEM** |
| 1.4.1.4.1.1.4.1.2.1. | **1st Fix** |
| 1.4.1.4.1.1.4.1.2.-1 | **2nd Fix** |
| 1.4.1.4.1.1.4.1.2.-2 | **PLM_Final Fix** |
| 1.4.1.4.1.1.4.1.3 | **ELECTRICAL / CONTROLS** |
| 1.4.1.4.1.1.4.1.3.1. | **1st Fix** |
| 1.4.1.4.1.1.4.1.3.-1 | **2nd Fix** |
| 1.4.1.4.1.1.4.1.3.-2 | **Elec._Final Fix** |
| 1.4.1.4.1.1.4.1.4 | **FIRE FIGHTING SYSTEM** |
| 1.4.1.4.1.1.4.1.4.1. | **1st Fix** |
| 1.4.1.4.1.1.4.1.4.-1 | **2nd Fix** |
| 1.4.1.4.1.1.4.1.4.-2 | **FF_Final Fix** |
| 1 | **NORTH GROUND - ZONE 01 AND 02** |
| 4 | **G00 - GROUND - ZONE 01** |
| 1.4.1.4.1.1.4.1.1 | **HVAC SYSTEM** |
| 1.4.1.4.1.1.4.1.1.1. | **1st Fix** |
| 1.4.1.4.1.1.4.1.1.-1 | **2nd Fix** |
| 1.4.1.4.1.1.4.1.1.-2 | **HVAC_Final Fix** |
| 1.4.1.4.1.1.4.1.2 | **PLUMBING SYSTEM** |
| 1.4.1.4.1.1.4.1.2.1. | **1st Fix** |
| 1.4.1.4.1.1.4.1.2.-1 | **2nd Fix** |
| 1.4.1.4.1.1.4.1.2.-2 | **PLM_Final Fix** |
| 1.4.1.4.1.1.4.1.3 | **ELECTRICAL / CONTROLS** |
| 1.4.1.4.1.1.4.1.3.1. | **1st Fix** |
| 1.4.1.4.1.1.4.1.3.-1 | **2nd Fix** |
| 1.4.1.4.1.1.4.1.3.-2 | **Elec._Final Fix** |
| 1.4.1.4.1.1.4.1.4 | **FIRE FIGHTING SYSTEM** |
| 1.4.1.4.1.1.4.1.4.1. | **1st Fix** |
| 1.4.1.4.1.1.4.1.4.-1 | **2nd Fix** |
| 1.4.1.4.1.1.4.1.4.-2 | **FF_Final Fix** |
| 5 | **G00 - GROUND - ZONE 02** |
| 1.4.1.4.1.1.4.1.1 | **HVAC SYSTEM** |
| 1.4.1.4.1.1.4.1.1.1. | **1st Fix** |
| 1.4.1.4.1.1.4.1.1.-1 | **2nd Fix** |
| 1.4.1.4.1.1.4.1.1.-2 | **HVAC_Final Fix** |
| 1.4.1.4.1.1.4.1.2 | **PLUMBING SYSTEM** |
| 1.4.1.4.1.1.4.1.2.1. | **1st Fix** |

| WBS | Activity |
| --- | --- |
| 1.4.1.4.1.1.4.1.2.-1 | **2nd Fix** |
| 1.4.1.4.1.1.4.1.2.-2 | **PLM_Final Fix** |
| 1.4.1.4.1.1.4.1.3 | **ELECTRICAL / CONTROLS** |
| 1.4.1.4.1.1.4.1.3.1. | **1st Fix** |
| 1.4.1.4.1.1.4.1.3.-1 | **2nd Fix** |
| 1.4.1.4.1.1.4.1.3.-2 | **Elec._Final Fix** |
| 1.4.1.4.1.1.4.1.4 | **FIRE FIGHTING SYSTEM** |
| 1.4.1.4.1.1.4.1.4.1. | **1st Fix** |
| 1.4.1.4.1.1.4.1.4.-1 | **2nd Fix** |
| 1.4.1.4.1.1.4.1.4.-2 | **FF_Final Fix** |
| 1.5 | **TESTING AND COMMISSIONING** |
| 1.5.1.5.1 | **GENERAL** |
| 1.6 | **HANDING OVER & PROJECT CLOSE-OUT** |
