# KPSS Additional Scope

Schedule from Primavera P6, 2016-07-26 to 2017-08-31, data date 2016-07-10.

## Calendars

- 6x10 KSA: Mon-Thu 07:00-17:00; Fri off; Sat-Sun 07:00-17:00. Exceptions (off unless hours are given): 2016-09-02, 2016-09-03 08:00-16:00, 2016-09-04 07:00-17:00, 2016-09-09, 2016-09-10 08:00-16:00, 2016-09-11 07:00-17:00, 2016-09-16, 2016-09-17 08:00-16:00, 2016-09-18 07:00-17:00, 2016-09-23, 2016-09-24 08:00-16:00, 2016-09-25 07:00-17:00, 2016-09-30.

## Resources

| Resource | Group |
| --- | --- |
| Manhour | labor |
| Contractor Material | material |

## Schedule

| ID | WBS | Activity | Type | Duration | Start | Finish | Predecessors | Total float | Constraint | Resources |
| --- | --- | --- | --- | --- | --- | --- | --- | --- | --- | --- |
| A10000 |  | MFC Signed with Contractor | milestone | 0d | 2016-07-26 | 2016-07-26 |  | 0d | start on or after 2016-07-10 |  |
|  | 1 | **Procurement** |  |  | 2016-08-09 | 2017-05-10 |  |  |  |  |
|  | 1 | **Truck Z-Portal Screening System** |  |  | 2016-08-09 | 2017-05-10 |  |  |  |  |
| A10930 |  | Issue RFQ |  | 1.07d | 2016-08-09 | 2016-08-09 | A10000 FS+16d | 0d |  | Contractor Material [10] |
| A10940 |  | Receive Bids - Perform Technical & Commercial Evaluation |  | 1.07d | 2016-09-01 | 2016-09-01 | A10930 FS+25.6d | 0d |  | Contractor Material [15] |
| A10950 |  | Select Vendor & Issue PO |  | 1.07d | 2016-09-19 | 2016-09-20 | A10940 FS+18.67d | 0d |  | Contractor Material [15] |
| A10960 |  | Receive 1st Set of Vendor Data-NMR 601 |  | 1.07d | 2016-10-23 | 2016-10-24 | A10950 FS+37.33d | 0d |  | Contractor Material [10] |
| A10970 |  | Certified Vendor Data-NMR 602 & Certifed WPS & PQRs |  | 1.07d | 2016-11-26 | 2016-11-26 | A10960 FS+37.33d | 0d |  | Contractor Material [10] |
| A10980 |  | Delivery of Materials |  | 60d | 2017-02-05 | 2017-03-28 | A10970 FS+80d | 0d |  | Contractor Material [30] |
| A10990 |  | Receipt of all NMR's related to PO |  | 1.07d | 2017-05-10 | 2017-05-10 | A10980 FS+48d | 65.33d |  | Contractor Material [10] |
|  | 2 | **License Plate Reader System** |  |  | 2016-08-09 | 2017-05-10 |  |  |  |  |
| A11000 |  | Issue RFQ |  | 1.07d | 2016-08-09 | 2016-08-09 | A10000 FS+16d | 0d |  | Contractor Material [10] |
| A11010 |  | Receive Bids - Perform Technical & Commercial Evaluation |  | 1.07d | 2016-09-01 | 2016-09-01 | A11000 FS+25.6d | 0d |  | Contractor Material [15] |
| A11020 |  | Select Vendor & Issue PO |  | 1.07d | 2016-09-19 | 2016-09-20 | A11010 FS+18.67d | 0d |  | Contractor Material [15] |
| A11030 |  | Receive 1st Set of Vendor Data-NMR 601 |  | 1.07d | 2016-10-23 | 2016-10-24 | A11020 FS+37.33d | 0d |  | Contractor Material [10] |
| A11040 |  | Certified Vendor Data-NMR 602 & Certifed WPS & PQRs |  | 1.07d | 2016-11-26 | 2016-11-26 | A11030 FS+37.33d | 0d |  | Contractor Material [10] |
| A11050 |  | Delivery of Materials |  | 60d | 2017-02-05 | 2017-03-28 | A11040 FS+80d | 0d |  | Contractor Material [30] |
| A11060 |  | Receipt of all NMR's related to PO |  | 1.07d | 2017-05-10 | 2017-05-10 | A11050 FS+48d | 65.33d |  | Contractor Material [10] |
|  | 3 | **Under Vehicle Inspection System** |  |  | 2016-08-09 | 2017-05-10 |  |  |  |  |
| A11070 |  | Issue RFQ |  | 1.07d | 2016-08-09 | 2016-08-09 | A10000 FS+16d | 0d |  | Contractor Material [10] |
| A11080 |  | Receive Bids - Perform Technical & Commercial Evaluation |  | 1.07d | 2016-09-01 | 2016-09-01 | A11070 FS+25.6d | 0d |  | Contractor Material [15] |
| A11090 |  | Select Vendor & Issue PO |  | 1.07d | 2016-09-19 | 2016-09-20 | A11080 FS+18.67d | 0d |  | Contractor Material [15] |
| A11100 |  | Receive 1st Set of Vendor Data-NMR 601 |  | 1.07d | 2016-10-23 | 2016-10-24 | A11090 FS+37.33d | 0d |  | Contractor Material [10] |
| A11110 |  | Certified Vendor Data-NMR 602 & Certifed WPS & PQRs |  | 1.07d | 2016-11-26 | 2016-11-26 | A11100 FS+37.33d | 0d |  | Contractor Material [10] |
| A11120 |  | Delivery of Materials |  | 60d | 2017-02-05 | 2017-03-28 | A11110 FS+80d | 0d |  | Contractor Material [30] |
| A11130 |  | Receipt of all NMR's related to PO |  | 1.07d | 2017-05-10 | 2017-05-10 | A11120 FS+48d | 65.33d |  | Contractor Material [10] |

| ID | WBS | Activity | Duration | Start | Finish | Predecessors | Total float | Free float | Resources |
| --- | --- | --- | --- | --- | --- | --- | --- | --- | --- |
|  | 4 | **Drop Arms** |  | 2016-08-09 | 2017-05-10 |  |  |  |  |
| A11140 |  | Issue RFQ | 1.07d | 2016-08-09 | 2016-08-09 | A10000 FS+16d | 3.73d | 0d | Contractor Material [10] |
| A11150 |  | Receive Bids - Perform Technical & Commercial Evaluation | 1.07d | 2016-09-01 | 2016-09-01 | A11140 FS+25.6d | 3.73d | 0d | Contractor Material [15] |
| A11160 |  | Select Vendor & Issue PO | 1.07d | 2016-09-19 | 2016-09-20 | A11150 FS+18.67d | 3.73d | 0d | Contractor Material [15] |
| A11170 |  | Receive 1st Set of Vendor Data-NMR 601 | 1.07d | 2016-10-23 | 2016-10-24 | A11160 FS+37.33d | 3.73d | 0d | Contractor Material [10] |
| A11180 |  | Certified Vendor Data-NMR 602 & Certifed WPS & PQRs | 1.33d | 2016-11-26 | 2016-11-27 | A11170 FS+37.33d | 3.73d | 0d | Contractor Material [10] |
| A11190 |  | Delivery of Materials | 60d | 2017-02-05 | 2017-03-29 | A11180 FS+80d | 3.73d | 0d | Contractor Material [30] |
| A11200 |  | Receipt of all NMR's related to PO | 1.07d | 2017-05-09 | 2017-05-10 | A11190 FS+47.47d | 65.6d |  | Contractor Material [10] |
|  | 5 | **Hydraulic Barriers** |  | 2016-08-09 | 2017-05-10 |  |  |  |  |
| A11210 |  | Issue RFQ | 1.07d | 2016-08-09 | 2016-08-09 | A10000 FS+16d | 32.8d | 0d | Contractor Material [10] |
| A11220 |  | Receive Bids - Perform Technical & Commercial Evaluation | 1.07d | 2016-09-01 | 2016-09-01 | A11210 FS+25.6d | 32.8d | 0d | Contractor Material [15] |
| A11230 |  | Select Vendor & Issue PO | 1.07d | 2016-09-19 | 2016-09-20 | A11220 FS+18.67d | 32.8d | 0d | Contractor Material [15] |
| A11240 |  | Receive 1st Set of Vendor Data-NMR 601 | 1.07d | 2016-10-23 | 2016-10-24 | A11230 FS+37.33d | 32.8d | 0d | Contractor Material [10] |
| A11250 |  | Certified Vendor Data-NMR 602 & Certifed WPS & PQRs | 1.07d | 2016-11-26 | 2016-11-26 | A11240 FS+37.33d | 32.8d | 0d | Contractor Material [10] |
| A11260 |  | Delivery of Materials | 60d | 2017-02-05 | 2017-03-28 | A11250 FS+80d | 32.8d | 0d | Contractor Material [30] |
| A11270 |  | Receipt of all NMR's related to PO | 1.07d | 2017-05-10 | 2017-05-10 | A11260 FS+48d | 65.33d |  | Contractor Material [10] |
|  | 6 | **Fixed Cameras & PTZ Cameras** |  | 2016-08-09 | 2017-05-10 |  |  |  |  |
| A11280 |  | Issue RFQ | 1.07d | 2016-08-09 | 2016-08-09 | A10000 FS+16d | 2.4d | 0d | Contractor Material [10] |
| A11290 |  | Receive Bids - Perform Technical & Commercial Evaluation | 1.07d | 2016-09-01 | 2016-09-01 | A11280 FS+25.6d | 2.4d | 0d | Contractor Material [15] |
| A11300 |  | Select Vendor & Issue PO | 1.07d | 2016-09-19 | 2016-09-20 | A11290 FS+18.67d | 2.4d | 0d | Contractor Material [15] |
| A11310 |  | Receive 1st Set of Vendor Data-NMR 601 | 1.07d | 2016-10-23 | 2016-10-24 | A11300 FS+37.33d | 2.4d | 0d | Contractor Material [10] |
| A11320 |  | Certified Vendor Data-NMR 602 & Certifed WPS & PQRs | 1.07d | 2016-11-26 | 2016-11-26 | A11310 FS+37.33d | 2.4d | 0d | Contractor Material [10] |
| A11330 |  | Delivery of Materials | 60d | 2017-02-05 | 2017-03-28 | A11320 FS+80d | 2.4d | 0d | Contractor Material [30] |
| A11340 |  | Receipt of all NMR's related to PO | 1.07d | 2017-05-10 | 2017-05-10 | A11330 FS+48d | 65.33d |  | Contractor Material [10] |

| ID | WBS | Activity | Duration | Start | Finish | Predecessors | Total float | Free float | Resources |
| --- | --- | --- | --- | --- | --- | --- | --- | --- | --- |
|  | 7 | **Microwave Systems(Rx & Tx)** |  | 2016-08-09 | 2017-05-10 |  |  |  |  |
| A11350 |  | Issue RFQ | 1.07d | 2016-08-09 | 2016-08-09 | A10000 FS+16d | 17.33d | 0d | Contractor Material [10] |
| A11360 |  | Receive Bids - Perform Technical & Commercial Evaluation | 1.07d | 2016-09-01 | 2016-09-01 | A11350 FS+25.6d | 17.33d | 0d | Contractor Material [15] |
| A11370 |  | Select Vendor & Issue PO | 1.07d | 2016-09-19 | 2016-09-20 | A11360 FS+18.67d | 17.33d | 0d | Contractor Material [15] |
| A11380 |  | Receive 1st Set of Vendor Data-NMR 601 | 1.07d | 2016-10-23 | 2016-10-24 | A11370 FS+37.33d | 17.33d | 0d | Contractor Material [10] |
| A11390 |  | Certified Vendor Data-NMR 602 & Certifed WPS & PQRs | 1.07d | 2016-11-26 | 2016-11-26 | A11380 FS+37.33d | 17.33d | 0d | Contractor Material [10] |
| A11400 |  | Delivery of Materials | 60d | 2017-02-05 | 2017-03-28 | A11390 FS+80d | 17.33d | 0d | Contractor Material [30] |
| A11410 |  | Receipt of all NMR's related to PO | 1.07d | 2017-05-10 | 2017-05-10 | A11400 FS+48d | 65.33d |  | Contractor Material [10] |
|  | 2 | **Construction** |  | 2017-03-29 | 2017-08-31 |  |  |  |  |
|  | 200 | **Upgrade KAUST Security Gate #1** |  | 2017-03-29 | 2017-07-06 |  |  |  |  |
| A10230 |  | Install Truck Z-Portal Vehicle Screening System | 64d | 2017-03-29 | 2017-05-23 | A10980 | 0d |  | Manhour [4800 h] |
| A10250 |  | Install LPRS (License Plate Reader System) | 64d | 2017-03-29 | 2017-05-23 | A11050 | 0d |  | Manhour [4800 h] |
| A10270 |  | Install UVIS (Under Vehicle Inspection System) | 64d | 2017-03-29 | 2017-05-23 | A11120 | 0d |  | Manhour [4800 h] |
| A10310 |  | Construct Operator Room for LPRS & UVIS | 64d | 2017-03-29 | 2017-05-23 | A10270 SS | 12d |  | Manhour [7200 h] |
| A10480 |  | Install Hydraulic Barrier with Speed Detection Loops | 48d | 2017-04-11 | 2017-05-23 | A11260 FS+14.93d | 32.8d |  | Manhour [2880 h] |
| A10460 |  | Install 2 Drop Arms | 40d | 2017-04-18 | 2017-05-22 | A11190 FS+22.4d | 3.73d |  | Manhour [2400 h] |
| A10490 |  | Upgrades to Roads and Pavements | 48d | 2017-04-30 | 2017-06-10 | A10230 FF+20d, A10250 FF+20d, A10270 FF+20d | 0d |  | Manhour [7200 h] |
| A10500 |  | Install Lighting System | 40d | 2017-05-23 | 2017-06-26 | A10310 FS-13.33d, A10490 FF+18.67d | 0d |  | Manhour [5400 h] |
| A10510 |  | Install MEP Systems | 40d | 2017-05-23 | 2017-06-26 | A10500 FF | 0d |  | Manhour [5400 h] |
| A10520 |  | Install Communication Systems | 40d | 2017-05-23 | 2017-06-26 | A10510 FF | 0d |  | Manhour [4500 h] |
| A10530 |  | Integrate All Security Systems | 48d | 2017-05-25 | 2017-07-06 | A10520 FF+11.73d, A10460, A10480 FF+18.67d | 0d |  | Manhour [4320 h] |
|  | 300 | **IDAS Under Culverts** |  | 2017-04-11 | 2017-07-04 |  |  |  |  |
| A10640 |  | Install Microwave Systems (Rx & Tx) | 40d | 2017-04-11 | 2017-05-16 | A11400 FS+14.93d | 17.33d | 14.93d | Manhour [2400 h] |
| A10620 |  | Install Fixed Cameras and PTZ Cameras | 40d | 2017-04-24 | 2017-05-29 | A11330 FS+29.87d | 2.4d | 0d | Manhour [3600 h] |
| A10650 |  | Install Electrical, FEC, Network and Communication Systems | 42.13d | 2017-05-29 | 2017-07-04 | A10640, A10620 | 2.4d |  | Manhour [3160 h] |

| ID | WBS | Activity | Duration | Start | Finish | Predecessors | Total float | Resources |
| --- | --- | --- | --- | --- | --- | --- | --- | --- |
|  | 700 | **MCC & Project Close-out** |  | 2017-07-06 | 2017-08-31 |  |  |  |
| A10900 |  | Precommissioning & Mechanical Completion | 64d | 2017-07-06 | 2017-08-31 | A10490, A10650, A10530, A10990, A11410, A11340, A11270, A11200, A11130, A11060, A10460, A10480 | 0d | Manhour [5760 h] |
