# KAUST-Baseline Schedule

Schedule from Primavera P6, 2011-01-09 to 2013-06-29, data date 2011-01-09, costs in SR.
Must finish by 2013-06-30

## Calendars

- SSH-Calendar: Mon-Thu 07:00-17:00; Fri off; Sat-Sun 07:00-17:00.

## Resources

| Resource | Group | Rate |
| --- | --- | --- |
| SSH-Construction Manhours | labor | 11 |
| Excavator | equipment |  |
| Dump Truck | equipment |  |
| Compactor | equipment |  |
| Grader | equipment |  |
| Cable Puller | equipment |  |
| Crane | equipment |  |
| Welding Machine | equipment |  |
| Asphalt Machine | equipment |  |
| Trailer | equipment |  |
| Fork-Lifter | equipment |  |
| SSH-Procurement Manhours | labor | 11 |
| SSH-Design Manhours | labor | 11 |

## Schedule

| ID | WBS | Activity | Type | Duration | Start | Finish | Predecessors | Total float | Free float | QTY |
| --- | --- | --- | --- | --- | --- | --- | --- | --- | --- | --- |
|  | M | **MILESTONE DATES** |  |  | 2011-01-09 | 2013-06-29 |  |  |  |  |
|  | 1 | **Milestone Dates** |  |  | 2011-01-09 | 2013-06-29 |  |  |  |  |
| M1.00 |  | Notice to Proceed (NTP) | milestone | 0d | 2011-01-09 | 2011-01-09 |  | 0d |  |  |
| M1.01 |  | PMT & Contractor Design Office | milestone | 0d | 2011-01-19 | 2011-01-19 | 1.2.1.010 | 63.75d | 0d |  |
| M1.02 |  | Submit 120 Days Schedule | milestone | 0d | 2011-02-08 | 2011-02-08 | 1.2.2.010, M1.01 | 65.75d | 0d |  |
| M1.03 |  | Complet Site Prep'n detailed design package | milestone | 0d | 2011-02-08 | 2011-02-08 | M1.02 | 85d | 4d |  |
| M1.04 |  | Submit Project Execution Plan (PEP) | milestone | 0d | 2011-02-23 | 2011-02-23 | 1.2.3.010, M1.03 | 81d | 0d |  |
| M1.05 |  | Submit Procurement Plan & Quality Plan | milestone | 0d | 2011-02-23 | 2011-02-23 | 1.2.3.015, M1.04 | 81d | 17.25d |  |
| M1.06 |  | Submit Work Schedule | milestone | 0d | 2011-03-10 | 2011-03-10 | 1.2.4.010, M1.05 | 63.75d |  |  |
| M2.01 |  | Compl't mobilization | milestone | 0d | 2011-03-10 | 2011-03-10 | M1.00, 1.4.1.1.230 | 117.5d | 56.25d |  |
| M2.02 |  | Compl't temporary construction site offices | milestone | 0d | 2011-03-10 | 2011-03-10 | M1.00 FS+43d, 1.4.1.1.230, 1.4.1.1.120 | 117.5d | 56.25d |  |
| M2.03 |  | Compl't inst'n of jersey barrier & gates for zone 1 | milestone | 0d | 2011-04-09 | 2011-04-09 | 1.4.1.3.1.010 | 86.25d | 25d |  |
| M1.08 |  | Complete 50% Engineering Design | milestone | 0d | 2011-05-09 | 2011-05-09 | 1.2.6.040 | 93.75d | 63.75d |  |
| M2.04 |  | Compl't inst'n of jersey barrier & gates for zone 3 | milestone | 0d | 2011-06-08 | 2011-06-08 | 1.4.1.3.3.010 | 90d | 28.75d |  |
| M2.05 |  | Compl't site prep & access road for zone 1 | milestone | 0d | 2011-06-08 | 2011-06-08 | Z1.1030, Z1.1030 FF | 110d | 47.5d |  |
| M1.11 |  | Compl't 90% Engineering Design | milestone | 0d | 2011-07-07 | 2011-07-07 | 1.2.6.120 | 30d | 0d |  |
| M2.06 |  | Compl't inst'n of jersey barrier & gates for zone 4 | milestone | 0d | 2011-07-23 | 2011-07-23 | 1.4.1.3.4.010 | 112.5d | 50d |  |
| M2.07 |  | Compl't inst'n of jersey barrier & gates for zone 2 | milestone | 0d | 2011-07-23 | 2011-07-23 | 1.4.1.3.2.010 | 62.5d | 0d |  |
| M1.12 |  | Issue 100% IFC Drwaings | milestone | 0d | 2011-08-07 | 2011-08-07 | 1.2.6.200, M1.11 | 179.75d | 123.75d |  |
| M1.07 |  | Place PO for Long Lead Items | milestone | 0d | 2011-08-13 | 2011-08-13 | M1.06, 1.2.5.010 SF | 174.75d | 75d |  |
| M2.08 |  | Compl't site prep & access road for zone 3 | milestone | 0d | 2011-09-06 | 2011-09-06 | Z3.1020, Z3.2030, Z3.3020, Z3.4020, Z3.5020 | 37.5d | 0d |  |
| M1.09 |  | Compl't PO Placement of Engineered Items | milestone | 0d | 2011-10-20 | 2011-10-20 | M1.08, 1.2.5.020, M1.07 | 99.75d | 43.75d |  |
| M2.09 |  | Compl't site prep & access roads for zone 2 & 4 | milestone | 0d | 2011-11-05 | 2011-11-05 | Z2.1020, Z2.2020, Z4.1020, Z2.2330 | 130d | 12.5d |  |
| M1.10 |  | Compl't PO Placement of Bulk Items | milestone | 0d | 2011-11-30 | 2011-11-30 | M1.09, 1.2.5.030 | 56d | 0d |  |
| M2.10 |  | Energize Substation 4 and 5 | milestone | 0d | 2012-08-21 | 2012-08-21 | 1.4.3.1.1.570, 1.4.3.1.2.570, 1.4.2.7.4.213, 1.4.2.7.4.153, 1.4.2.7.4.231, 1.4.2.7.4.233, 1.4.2.7.4.193, 1.4.2.7.4.025, 1.4.2.7.4.055 | 37.75d | 0d |  |
| M2.11 |  | Compl't Communications and Security Cabling | milestone | 0d | 2012-09-20 | 2012-09-20 | 1.4.2.8.1.090, 1.4.2.8.1.110, 1.4.3.2.1.1010 | 94.25d |  |  |
| M2.12 |  | Communications and Security Systems | milestone | 0d | 2012-09-20 | 2012-09-20 | 1.4.3.2.1.1110 | 94d |  |  |
| M2.13 |  | Compl't Power System | milestone | 0d | 2012-09-20 | 2012-09-20 | 1.4.2.7.4.015, 1.4.2.7.4.211, 1.4.2.7.4.271, 1.4.2.7.2.050, 1.4.2.7.2.090, 1.4.2.7.4.273 | 93.75d |  |  |
| M2.14 |  | Compl't Const'n & Energize the Comm'n Bld'g | milestone | 0d | 2012-09-30 | 2012-09-30 | 1.4.3.2.1.1340, 1.4.3.2.1.1520, 1.4.3.2.1.890, 1.4.3.2.1.940 | 51.5d | 21.5d |  |
| M2.19 |  | Compl't Spare Part Data Packages | milestone | 0d | 2012-10-20 | 2012-10-20 | 1.4.4.2.010, 1.4.4.1.030 | 62.75d |  |  |
| M2.15 |  | Compl't Potable and Fire Water Systems | milestone | 0d | 2012-10-20 | 2012-10-20 | Z3.1320, Z3.2290, Z3.3270, Z2.1110, Z2.2310, Z4.1160, Z1.1060 | 62.5d |  |  |
| M2.16 |  | Compl't Irrigation System | milestone | 0d | 2012-10-20 | 2012-10-20 | 1.3.5.3.4.020, 1.3.5.3.3.020, Z3.1330, Z3.2300, Z2.2290 | 62.5d |  |  |
| M2.17 |  | Compl't Sanitary Sewer System | milestone | 0d | 2012-10-20 | 2012-10-20 | 1.4.2.3.5.140, 1.4.2.3.6.140, 1.4.2.3.7.140, 1.4.2.3.8.140, 1.4.2.7.4.121, 1.4.2.7.4.171, 1.4.2.3.7.150, 1.4.2.3.5.150, 1.4.2.3.8.150, 1.4.2.3.6.160, 1.4.2.3.7.160, 1.4.2.3.8.160, 1.4.2.3.5.160, 1.4.2.7.4.173, 1.4.2.7.4.175, 1.4.2.7.4.177, 1.4.2.7.4.123, 1.4.2.7.4.125, 1.4.2.7.4.127 | 30d | 0d |  |
| M2.18 |  | Compl't Storm Drainage System | milestone | 0d | 2012-10-20 | 2012-10-20 | 1.4.2.4.2.050B, 1.4.2.4.2.090B, 1.4.2.4.2.040, 1.4.2.4.3.040, 1.4.2.4.1.015, 1.4.2.4.2.093C, 1.4.2.4.2.053C, 1.4.2.4.3.106C, 1.4.2.4.3.116C, 1.4.2.4.3.340, 1.4.2.4.4.120C, Z3.4060, Z3.5080, 1.4.2.4.2.054C, 1.4.2.4.3.070, 1.4.2.4.3.450, 1.4.2.4.3.530, 1.4.2.4.3.500, 1.4.2.4.3.720, 1.4.2.4.4.080 | 62.5d |  |  |
| M2.20 |  | Compl't Redlined As-Built drawings | milestone | 0d | 2012-11-19 | 2012-11-19 | 1.4.4.5.040, 1.4.1.1.200 | 30d |  |  |
| M2.21 |  | Mech'l Compl'n Certific'n of all works | milestone | 0d | 2012-12-29 | 2012-12-29 | 1.4.4.6.010, M1.12, M2.01, M2.02, M2.03, M2.04, M2.05, M2.06, M2.07, M2.08, M2.09, M2.10, M2.11, M2.12, M2.13, M2.14, M2.15, M2.16, M2.17, M2.18, M2.19, M2.20, 1.4.2.5.6.020A, 1.4.2.5.5.010C, 1.4.2.6.140, 1.4.3.3.1.3.120, 1.4.3.3.1.3.150, 1.4.3.3.1.3.180, 1.4.3.3.1.3.210, 1.4.3.3.1.3.300, 1.4.3.3.1.2.120, 1.4.3.5.1.140, 1.4.3.6.1.150, 1.4.3.4.4.170, 1.4.3.7.1.140, 1.4.3.7.1.100, 1.4.3.1.1.780, 1.4.3.1.1.820, 1.4.2.6.150, 1.4.3.6.1.100, 1.4.3.3.1.2.210, 1.4.3.3.1.2.180, 1.4.3.3.1.2.300, 1.4.3.3.1.1.210, 1.4.3.3.1.1.120, 1.4.3.3.1.1.300, 1.4.2.7.4.075, 1.4.2.6.120, 1.4.2.6.090, 1.4.2.5.6.020D, 1.4.2.5.5.050C, 1.4.2.6.170, 1.4.2.5.3.110, 1.4.2.5.4.050, 1.4.3.4.3.170 | 80d | 0d |  |
| M2.22 |  | Compl't all As-Built CAD work | milestone | 0d | 2013-01-28 | 2013-01-28 | 1.2.9.020 | 80d |  |  |
| M2.23 |  | Scheduled Completion Date and Demobilization | milestone | 0d | 2013-06-29 | 2013-06-29 | M2.21, M2.22, M2.10, 1.4.5.1.040 | 0d |  | 0 |

| ID | WBS | Activity | Duration | Start | Finish | Predecessors | Total float | Free float | Resources | Cost | QTY |
| --- | --- | --- | --- | --- | --- | --- | --- | --- | --- | --- | --- |
|  | E | **DETAILED ENGINEERING / DESIGN** |  | 2011-01-09 | 2013-01-28 |  |  |  |  |  |  |
|  | 1 | **Categories 1** |  | 2011-01-09 | 2011-01-19 |  |  |  |  |  |  |
|  | 1 | **Categories 1** |  | 2011-01-09 | 2011-01-19 |  |  |  |  |  |  |
| 1.2.1.010 |  | PMT & Contractor Design office | 12d | 2011-01-09 | 2011-01-19 | M1.00 | 0d |  | SSH-Design Manhours [5000 h] | 50,000 | 0.0147698364 |
|  | 2 | **Categories 2** |  | 2011-01-19 | 2011-02-22 |  |  |  |  |  |  |
|  | 1 | **Categories 2** |  | 2011-01-19 | 2011-02-22 |  |  |  |  |  |  |
| 1.2.2.010 |  | Submit 120 days schedule | 21d | 2011-01-19 | 2011-02-08 | 1.2.1.010, M1.01 | 63.75d | 0d | SSH-Design Manhours [4000 h] | 40,000 |  |
| 1.2.2.020 |  | Submit drawing & document control index | 21d | 2011-02-02 | 2011-02-22 | 1.2.2.010 SS+15d | 63.75d | 0d | SSH-Design Manhours [3000 h] | 30,000 | 0.0088619018 |
|  | 3 | **Categories 3** |  | 2011-02-10 | 2011-02-23 |  |  |  |  |  |  |
|  | 1 | **Categories 3** |  | 2011-02-10 | 2011-02-23 |  |  |  |  |  |  |
| 1.2.3.010 |  | Submit project execution plan PEP | 14d | 2011-02-10 | 2011-02-23 | 1.2.2.020 SS+8d, M1.02 | 63.75d | 0d | SSH-Design Manhours [2500 h] | 25,000 |  |
| 1.2.3.015 |  | Submit Procurement plan & Quality Plan | 12d | 2011-02-12 | 2011-02-23 | 1.2.2.020 SS+10d, M1.03 | 81d | 0d | SSH-Design Manhours [2500 h] |  | 0.0059079345 |
|  | 4 | **Categories 4** |  | 2011-02-20 | 2011-03-10 |  |  |  |  |  |  |
|  | 1 | **Categories 4** |  | 2011-02-20 | 2011-03-10 |  |  |  |  |  |  |
| 1.2.4.010 |  | Submit contractor deliverables & Work Schedule | 21.25d | 2011-02-20 | 2011-03-10 | 1.2.3.010 SS+10d | 63.75d | 0d | SSH-Design Manhours [6000 h] | 60,000 | 0.0177238036 |
|  | 5 | **Categories 5** |  | 2011-08-13 | 2011-11-30 |  |  |  |  |  |  |
|  | 1 | **Categories 5** |  | 2011-08-13 | 2011-11-30 |  |  |  |  |  |  |
| 1.2.5.010 |  | Purchase orders placed for long lead items | 37.5d | 2011-08-13 | 2011-09-15 | 1.3.2.1.010 | 56d | 0d | SSH-Design Manhours [18000 h] | 180,000 |  |
| 1.2.5.020 |  | Purchase orders placed for all engineered items | 37.5d | 2011-09-17 | 2011-10-20 | 1.2.5.010 | 56d | 0d | SSH-Design Manhours |  |  |
| 1.2.5.030 |  | Purchase orders placed for all bulk items | 43.75d | 2011-10-22 | 2011-11-30 | 1.3.1.1.010 SS, 1.2.5.020 | 56d | 0d | SSH-Design Manhours |  | 0.0177238036 |
|  | 6 | **Categories 6** |  | 2011-01-27 | 2011-08-07 |  |  |  |  |  |  |
|  | 1 | **Categories 6** |  | 2011-01-27 | 2011-08-07 |  |  |  |  |  |  |
| 1.2.6.010 |  | Preparation of 50% Civil drawings | 37.5d | 2011-01-27 | 2011-03-02 | 1.2.1.010 FS+8d | 0d |  | SSH-Design Manhours [60000 h] | 1,000,000 |  |
| 1.2.6.020 |  | Preparation of 50% Mechanical drawings | 37.5d | 2011-02-20 | 2011-03-26 | 1.2.6.010 SS+25d | 0d |  | SSH-Design Manhours [60000 h] | 1,500,000 |  |
| 1.2.6.030 |  | Preparation of 50% Electrical drawings | 37.5d | 2011-03-15 | 2011-04-18 | 1.2.6.020 SS+25d | 0d |  | SSH-Design Manhours [60000 h] | 1,500,000 |  |
| 1.2.6.040 |  | Preparation of 50% Communication drawings | 37.5d | 2011-04-05 | 2011-05-09 | 1.2.6.030 SS+22.5d | 0d |  | SSH-Design Manhours [60000 h] | 1,300,000 |  |
| 1.2.6.090 |  | Preparation of 90% Civil drawings | 25d | 2011-05-10 | 2011-06-01 | 1.2.6.040, M1.04, M1.05, M1.06 | 0d |  | SSH-Design Manhours [40000 h] | 600,000 |  |
| 1.2.6.100 |  | Preparation of 90% Mechancial drawings | 25d | 2011-05-22 | 2011-06-13 | 1.2.6.090 SS+12.5d | 0d |  | SSH-Design Manhours [40000 h] | 750,000 |  |
| 1.2.6.110 |  | Preparation of 90% Electrical drawings | 25d | 2011-06-02 | 2011-06-25 | 1.2.6.100 SS+12.5d | 0d |  | SSH-Design Manhours [40000 h] | 750,000 |  |
| 1.2.6.120 |  | Preparation of 90% Communication drawings | 26.25d | 2011-06-14 | 2011-07-07 | 1.2.6.110 SS+12.5d | 0d |  | SSH-Design Manhours [40000 h] | 700,000 | 0.2067777089 |
| 1.2.6.200 |  | Submit 100% IFC drawings | 32.5d | 2011-07-09 | 2011-08-07 | 1.2.6.120, 1.2.2.010, 1.2.2.020, 1.2.3.010, 1.2.3.015, 1.2.4.010, M1.08, M1.11 | 30d | 0d | SSH-Design Manhours [98290 h] | 75,000 |  |

| ID | WBS | Activity | Duration | Start | Finish | Predecessors | Total float | Free float | Resources | Cost | QTY |
| --- | --- | --- | --- | --- | --- | --- | --- | --- | --- | --- | --- |
|  | 7 | **Categories 7** |  | 2012-09-29 | 2012-10-27 |  |  |  |  |  |  |
|  | 1 | **Categories 7** |  | 2012-09-29 | 2012-10-27 |  |  |  |  |  |  |
| 1.2.7.010 |  | Submit Project Record books | 30d | 2012-09-29 | 2012-10-27 | 1.2.6.200 FS+300d, 1.2.5.030, 1.4.4.3.010 | 147.75d | 67.75d | SSH-Design Manhours [6000 h] | 60,000 |  |
|  | 8 | **Categories 8** |  | 2012-01-24 | 2012-06-11 |  |  |  |  |  |  |
|  | 1 | **Categories 8** |  | 2012-01-24 | 2012-06-11 |  |  |  |  |  |  |
| 1.2.8.010 |  | Submit Pre-commissioning Plans | 75d | 2012-01-24 | 2012-04-02 | 1.2.6.200 FS+181.25d | 95d | 0d | SSH-Design Manhours [2500 h] | 25,000 |  |
| 1.2.8.020 |  | Approved Pre-commissioning Plans | 75d | 2012-04-03 | 2012-06-11 | 1.2.8.010 | 95d | 57d | SSH-Design Manhours [2500 h] | 25,000 | 0.0073849182 |
|  | 9 | **Categories 9** |  | 2012-12-30 | 2013-01-28 |  |  |  |  |  |  |
|  | 1 | **Categories 9** |  | 2012-12-30 | 2013-01-28 |  |  |  |  |  |  |
| 1.2.9.010 |  | Complete As built Red lined drawings & CAD-work | 32.5d | 2012-12-30 | 2013-01-28 | 1.4.3.1.2.570, 1.4.4.5.040, 1.2.7.010, 1.4.4.6.010, M2.21 | 80d | 0d | SSH-Design Manhours [12000 h] | 120,000 |  |
| 1.2.9.020 |  | Complete Intergraph CADD | 32.5d | 2012-12-30 | 2013-01-28 | 1.2.9.010 SS | 80d | 0d | SSH-Design Manhours [1000 h] | 100,000 |  |
|  | P.1.3 | **PROCUREMENT** |  | 2011-02-01 | 2012-11-03 |  |  |  |  |  |  |
|  | 1 | **CIVIL WORKS** |  | 2011-02-01 | 2012-11-03 |  |  |  |  |  |  |
|  | 1 | **Civil Works & Road Related Materials** |  | 2011-02-01 | 2012-11-03 |  |  |  |  |  |  |
|  | 01 | **FBE coated rebars** |  | 2011-07-20 | 2012-06-26 |  |  |  |  |  |  |
| 1.3.1.1.010 |  | Place PO for FBE coated rebars | 32.5d | 2011-07-20 | 2011-08-18 | 1.2.6.120 FS+12.5d | 0d |  | SSH-Procurement Manhours |  |  |
| 1.3.1.1.020 |  | Delivery of FBE coated rebars on site | 312.5d | 2011-09-10 | 2012-06-26 | 1.3.1.1.010 FS+22.5d | 110d | 0d | SSH-Procurement Manhours | 5,100,000 |  |
| 1.3.1.1.030 |  | Material receiving inspection & approval | 312.5d | 2011-09-10 | 2012-06-26 | 1.3.1.1.020 SS | 110d | 52.5d | SSH-Procurement Manhours |  | 0.3013046616 |
|  | 02 | **Structural Steel** |  | 2011-07-23 | 2011-09-29 |  |  |  |  |  |  |
| 1.3.1.1.110 |  | Place PO for structural stell | 37.5d | 2011-07-23 | 2011-08-27 | 1.3.1.1.010 SS+3d | 0d |  | SSH-Procurement Manhours |  |  |
| 1.3.1.1.120 |  | Delivery of structural steel on site | 5d | 2011-09-19 | 2011-09-24 | 1.3.1.1.110 FS+25d | 88.5d | 0d | SSH-Procurement Manhours | 1,800,000 |  |
| 1.3.1.1.130 |  | Material receiving inspection & approval | 6d | 2011-09-24 | 2011-09-29 | 1.3.1.1.120 | 88.5d | 31d | SSH-Procurement Manhours |  | 0.1358824944 |
|  | 03 | **Geogrid & Geotextile Materials** |  | 2011-08-29 | 2012-04-04 |  |  |  |  |  |  |
| 1.3.1.1.210 |  | Place PO for geogrid/geotextile materials | 37.5d | 2011-08-29 | 2011-10-03 | 1.3.1.1.110 SS+40d | 0d |  | SSH-Procurement Manhours |  |  |
| 1.3.1.1.220 |  | Delivery of geogrid/geotextile materials on site | 6d | 2012-03-25 | 2012-03-31 | 1.3.1.1.210 FS+186.25d | 0d |  | SSH-Procurement Manhours | 1,020,000 |  |
| 1.3.1.1.230 |  | Material receiving inspection & approval | 6d | 2012-03-31 | 2012-04-04 | 1.3.1.1.220 | 0d |  | SSH-Procurement Manhours |  | 0.0602609323 |

| ID | WBS | Activity | Duration | Start | Finish | Predecessors | Total float | Free float | Resources | Cost | QTY |
| --- | --- | --- | --- | --- | --- | --- | --- | --- | --- | --- | --- |
|  | 04 | **Ceramic Tiles** |  | 2011-07-27 | 2012-01-29 |  |  |  |  |  |  |
| 1.3.1.2.010 |  | Place PO for ceramic tiles | 37.5d | 2011-07-27 | 2011-08-31 | 1.3.1.1.110 SS+5d | 48.75d | 0d | SSH-Procurement Manhours |  |  |
| 1.3.1.2.020 |  | Delivery of ceramic tiles on site | 5d | 2012-01-18 | 2012-01-23 | 1.3.1.2.010 FS+150d | 48.75d | 0d | SSH-Procurement Manhours | 1,186,000 |  |
| 1.3.1.2.030 |  | Material receiving inspection & approval | 6d | 2012-01-23 | 2012-01-29 | 1.3.1.2.020 | 48.75d | 9.75d | SSH-Procurement Manhours |  | 0.0759760382 |
|  | 05 | **CMU Blocks** |  | 2011-10-03 | 2012-01-09 |  |  |  |  |  |  |
| 1.3.1.3.010 |  | Place PO for CMU blocks | 37.5d | 2011-10-03 | 2011-11-07 | 1.3.1.1.210 | 39d | 0d | SSH-Procurement Manhours |  |  |
| 1.3.1.3.020 |  | Delivery of CMU blocks | 6d | 2011-12-29 | 2012-01-04 | 1.3.1.3.010 FS+56.25d | 39d | 0d | SSH-Procurement Manhours | 1,600,000 |  |
| 1.3.1.3.030 |  | Material receiving inspection & approval | 6d | 2012-01-04 | 2012-01-09 | 1.3.1.3.020 | 39d | 0d | SSH-Procurement Manhours |  | 0.1004348872 |
|  | 06 | **Concrete Tiles** |  | 2011-09-04 | 2012-04-11 |  |  |  |  |  |  |
| 1.3.1.2.040 |  | Place PO for concrete tiles | 37.5d | 2011-09-04 | 2011-10-09 | 1.3.1.1.210 SS+6.25d | 37.25d | 0d | SSH-Procurement Manhours |  |  |
| 1.3.1.2.050 |  | Delivery of concrete tiles | 5d | 2012-04-01 | 2012-04-05 | 1.3.1.2.040 FS+187.5d | 37.25d | 0d | SSH-Procurement Manhours | 1,794,000 |  |
| 1.3.1.2.060 |  | Material receiving inspection & approval | 6d | 2012-04-05 | 2012-04-11 | 1.3.1.2.050 | 37.25d | 31d | SSH-Procurement Manhours |  | 0.1059883457 |
|  | 07 | **Doors & Frames** |  | 2011-09-15 | 2012-03-07 |  |  |  |  |  |  |
| 1.3.1.4.010 |  | Place PO for doors & frames | 37.5d | 2011-09-15 | 2011-10-20 | 1.3.1.2.040 SS+12.5d | 66.75d | 0d | SSH-Procurement Manhours |  |  |
| 1.3.1.4.020 |  | Delivery of doors & frames on site | 5d | 2012-02-26 | 2012-03-01 | 1.3.1.4.010 FS+137.5d | 201d | 0d | SSH-Procurement Manhours | 508,500 |  |
| 1.3.1.4.030 |  | Material receiving inspection & approval | 6d | 2012-03-01 | 2012-03-07 | 1.3.1.4.020 | 201d | 22.25d | SSH-Procurement Manhours |  | 0.0300418471 |
|  | 08 | **Aluminium Windows** |  | 2011-09-18 | 2012-03-10 |  |  |  |  |  |  |
| 1.3.1.4.040 |  | Place PO for windows | 37.5d | 2011-09-18 | 2011-10-23 | 1.3.1.4.010 SS+2.5d | 66.75d | 0d | SSH-Procurement Manhours |  |  |
| 1.3.1.4.050 |  | Delivery of windows on site | 5d | 2012-02-28 | 2012-03-04 | 1.3.1.4.040 FS+137.5d | 198.5d | 0d | SSH-Procurement Manhours | 356,500 |  |
| 1.3.1.4.060 |  | Material receiving inspection & approval | 6d | 2012-03-04 | 2012-03-10 | 1.3.1.4.050 | 198.5d | 19.75d | SSH-Procurement Manhours |  | 0.003337983 |
|  | 09 | **Jersey Barriers** |  | 2011-02-01 | 2011-07-17 |  |  |  |  |  |  |
| 1.3.1.5.010 |  | Place PO for Jersey Barriers materials Materials | 7.5d | 2011-02-01 | 2011-02-07 | M1.00 FS+25d | 37.5d | 0d | SSH-Procurement Manhours |  |  |
| 1.3.1.5.020 |  | Fabrication & Delivery of materials for jersey bariers | 150d | 2011-02-19 | 2011-07-07 | 1.3.1.5.010 FS+11.25d | 57.5d | 0d | SSH-Procurement Manhours; SSH-Construction Manhours [900000 h] | 10,000,000 |  |
| 1.3.1.5.030 |  | Insp/Transporation of Jersey Barriers | 150d | 2011-02-28 | 2011-07-17 | 1.3.1.5.020 SS+10d | 57.5d | 20d | SSH-Procurement Manhours |  | 1.0929678901 |

| ID | WBS | Activity | Duration | Start | Finish | Predecessors | Total float | Free float | Resources | Cost | QTY |
| --- | --- | --- | --- | --- | --- | --- | --- | --- | --- | --- | --- |
|  | 10 | **Sliding & Swing Gates** |  | 2011-02-14 | 2011-03-17 |  |  |  |  |  |  |
| 1.3.1.5.110 |  | Place PO for sliding & swing gates | 7.5d | 2011-02-14 | 2011-02-20 | 1.3.1.5.010 FS+6.25d | 37.5d | 0d | SSH-Procurement Manhours |  |  |
| 1.3.1.5.120 |  | Delivery of sliding & swing gates | 5d | 2011-03-10 | 2011-03-14 | 1.3.1.5.110 FS+18.75d | 37.5d | 0d | SSH-Procurement Manhours | 85,000 |  |
| 1.3.1.5.130 |  | Material receiving inspection & approval | 3.75d | 2011-03-15 | 2011-03-17 | 1.3.1.5.120 | 37.5d | 0d | SSH-Procurement Manhours |  | 0.0050217444 |
|  | 11 | **Suspended Ceiling System** |  | 2011-10-10 | 2012-04-28 |  |  |  |  |  |  |
| 1.3.1.5.210 |  | Place PO for suspended ceiling system | 37.5d | 2011-10-10 | 2011-11-14 | 1.3.1.4.040 SS+23.75d | 66.75d | 0d | SSH-Procurement Manhours |  |  |
| 1.3.1.5.220 |  | Delivery of suspended ceiling system | 6d | 2012-04-17 | 2012-04-23 | 1.3.1.5.210 FS+166.25d | 122.5d | 0d | SSH-Procurement Manhours | 900,000 |  |
| 1.3.1.5.230 |  | Material receiving inspection & approval | 6d | 2012-04-23 | 2012-04-28 | 1.3.1.5.220 | 122.5d | 55.75d | SSH-Procurement Manhours |  | 0.0590793454 |
|  | 12 | **Dry Wall Partition** |  | 2011-10-10 | 2012-04-28 |  |  |  |  |  |  |
| 1.3.1.5.310 |  | Place PO for dry wall partition | 37.5d | 2011-10-10 | 2011-11-14 | 1.3.1.5.210 SS | 66.75d | 0d | SSH-Procurement Manhours |  |  |
| 1.3.1.5.320 |  | Delivery of dry wall partition on site | 6d | 2012-04-17 | 2012-04-23 | 1.3.1.5.310 FS+166.25d | 70.5d | 0d | SSH-Procurement Manhours | 500,000 |  |
| 1.3.1.5.330 |  | Material receiving inspection & approval | 6d | 2012-04-23 | 2012-04-28 | 1.3.1.5.320 | 70.5d | 3.75d | SSH-Procurement Manhours |  | 0.0590793454 |
|  | 13 | **Pre-Cast Concrete Wall** |  | 2011-10-15 | 2012-05-01 |  |  |  |  |  |  |
| 1.3.1.5.410 |  | Place PO for precast concrete wall | 37.5d | 2011-10-15 | 2011-11-19 | 1.3.1.5.310 SS+5d | 66.75d | 0d | SSH-Procurement Manhours |  |  |
| 1.3.1.5.420 |  | Delivery of precast concrete wall | 6d | 2012-04-21 | 2012-04-26 | 1.3.1.5.410 FS+165d | 66.75d | 0d | SSH-Procurement Manhours | 900,000 |  |
| 1.3.1.5.430 |  | Material receiving inspection & approval | 6d | 2012-04-26 | 2012-05-01 | 1.3.1.5.420 | 66.75d | 0d | SSH-Procurement Manhours |  | 0.0590793454 |
|  | 14 | **Concrete** |  | 2011-02-01 | 2012-11-03 |  |  |  |  |  |  |
| 1.3.1.6.110 |  | Place PO for Concrete | 6.25d | 2011-02-01 | 2011-02-06 | 1.3.1.5.010 SS | 48.75d | 0d | SSH-Procurement Manhours |  |  |
| 1.3.1.6.120 |  | Delivery of concrete on site | 650d | 2011-03-08 | 2012-11-03 | 1.3.1.6.110 SS+37.5d | 48.75d | 11.25d | SSH-Procurement Manhours | 2,450,000 |  |
|  | 15 | **Aggregate, Crushed Stone & Backfilling Materials** |  | 2011-02-16 | 2011-09-25 |  |  |  |  |  |  |
| 1.3.1.6.130 |  | Place PO for Aggregate & Backfill materials | 37.5d | 2011-02-16 | 2011-03-22 | 1.3.1.6.110 FS+10d | 49d | 0d | SSH-Procurement Manhours |  |  |
| 1.3.1.6.140 |  | Delivery of Aggregate & Backfill materials | 187.5d | 2011-04-04 | 2011-09-25 | 1.3.1.6.130 FS+12.5d | 131.25d | 21.25d | SSH-Procurement Manhours | 4,500,000 |  |
|  | 16 | **Premix** |  | 2011-07-06 | 2012-04-15 |  |  |  |  |  |  |
| 1.3.1.6.150 |  | Place PO for Premix | 37.5d | 2011-07-06 | 2011-08-09 | 1.3.1.6.130 FS+112.5d | 49d | 0d | SSH-Procurement Manhours |  |  |
| 1.3.1.6.160 |  | Delivery of Premix | 5d | 2012-04-11 | 2012-04-15 | 1.3.1.6.150 FS+262.5d | 120d |  | SSH-Procurement Manhours | 500,000 |  |

| ID | WBS | Activity | Duration | Start | Finish | Predecessors | Total float | Free float | Resources | Cost | QTY |
| --- | --- | --- | --- | --- | --- | --- | --- | --- | --- | --- | --- |
|  | 17 | **Road Signange & Markings** |  | 2011-10-15 | 2012-03-08 |  |  |  |  |  |  |
| 1.3.1.6.170 |  | Place PO for road signage, markings | 37.5d | 2011-10-15 | 2011-11-19 | 1.3.1.5.410 SS | 198.25d | 0d | SSH-Procurement Manhours |  |  |
| 1.3.1.6.180 |  | Delivery of road signage , markings | 6.25d | 2012-03-03 | 2012-03-08 | 1.3.1.6.170 FS+112.5d | 198.25d | 192d | SSH-Procurement Manhours | 750,000 |  |
|  | 18 | **Ironmongery** |  | 2011-09-03 | 2012-01-25 |  |  |  |  |  |  |
| 1.3.1.6.190 |  | Place PO for Ironmongery | 37.5d | 2011-09-03 | 2011-10-06 | 1.3.1.6.150 FS+25d | 49d | 0d | SSH-Procurement Manhours |  |  |
| 1.3.1.6.200 |  | Delivery of Ironmongery | 6.25d | 2012-01-21 | 2012-01-25 | 1.3.1.6.190 FS+112.5d | 71d | 15d | SSH-Procurement Manhours | 300,000 |  |
|  | 19 | **Paint** |  | 2011-09-07 | 2012-02-11 |  |  |  |  |  |  |
| 1.3.1.6.210 |  | Place PO for Paint | 37.5d | 2011-09-07 | 2011-10-11 | 1.3.1.6.190 SS+5d | 49d | 0d | SSH-Procurement Manhours |  |  |
| 1.3.1.6.220 |  | Delivery of Paint | 6.25d | 2012-02-06 | 2012-02-11 | 1.3.1.6.210 FS+125d | 49d | 10d | SSH-Procurement Manhours | 250,000 |  |
|  | 20 | **Roofing Materials, membrane etc.** |  | 2011-10-12 | 2012-03-01 |  |  |  |  |  |  |
| 1.3.1.6.230 |  | Place PO for Roofing Materials & Membrane | 37.5d | 2011-10-12 | 2011-11-15 | 1.3.1.6.210 SS+37.5d | 206.25d | 0d | SSH-Procurement Manhours |  |  |
| 1.3.1.6.240 |  | Delivery of roofing Materials & Membrane | 2.5d | 2012-02-29 | 2012-03-01 | 1.3.1.6.230 FS+112.5d | 206.25d | 0d | SSH-Procurement Manhours | 300,000 |  |
|  | 21 | **Building Signage** |  | 2011-10-12 | 2012-03-15 |  |  |  |  |  |  |
| 1.3.1.6.250 |  | Place PO for Building Signage | 37.5d | 2011-10-12 | 2011-11-15 | 1.3.1.6.210 SS+37.5d | 178.75d | 0d | SSH-Procurement Manhours |  |  |
| 1.3.1.6.260 |  | Delivery of Buiding Signage | 5d | 2012-03-12 | 2012-03-15 | 1.3.1.6.250 FS+125d | 191.25d | 12.5d | SSH-Procurement Manhours | 300,000 |  |
|  | 22 | **Wood Terrlis** |  | 2011-10-12 | 2012-03-27 |  |  |  |  |  |  |
| 1.3.1.6.270 |  | Place PO for Wood Terrlis | 37.5d | 2011-10-12 | 2011-11-15 | 1.3.1.6.250 SS | 178.75d | 0d | SSH-Procurement Manhours |  |  |
| 1.3.1.6.280 |  | Delivery of Wood Terrlis | 5d | 2012-03-24 | 2012-03-27 | 1.3.1.6.270 FS+137.5d | 178.75d | 0d | SSH-Procurement Manhours | 250,000 |  |
|  | 2 | **ELECTRICAL WORKS** |  | 2011-07-09 | 2012-06-21 |  |  |  |  |  |  |
|  | 1 | **Switchgears** |  | 2011-07-09 | 2012-04-12 |  |  |  |  |  |  |
|  | 1 | **Switchgears** |  | 2011-07-09 | 2012-04-12 |  |  |  |  |  |  |
| 1.3.2.1.010 |  | Place PO for switchgears | 37.5d | 2011-07-09 | 2011-08-11 | 1.2.6.120 | 19.25d | 0d | SSH-Procurement Manhours | 605,100 |  |
| 1.3.2.1.020 |  | Delivery of switchgears | 6d | 2012-04-02 | 2012-04-07 | 1.3.2.1.010 FS+250d | 43d | 0d | SSH-Procurement Manhours | 4,235,700 |  |
| 1.3.2.1.030 |  | Provision of startup spare parts & Non-material-req'ts | 6d | 2012-04-07 | 2012-04-12 | 1.3.2.1.020 | 43d | 5.25d | SSH-Procurement Manhours | 1,210,200 | 0.5612537814 |

| ID | WBS | Activity | Duration | Start | Finish | Predecessors | Total float | Free float | Resources | Cost | QTY |
| --- | --- | --- | --- | --- | --- | --- | --- | --- | --- | --- | --- |
|  | 2 | **MCC -Motor Control Center** |  | 2011-08-09 | 2012-03-29 |  |  |  |  |  |  |
| 1.3.2.1.040 |  | Place PO for MCC | 37.5d | 2011-08-09 | 2011-09-12 | 1.3.2.1.010 SS+33.75d | 132.75d | 0d | SSH-Procurement Manhours | 403,400 |  |
| 1.3.2.1.050 |  | Delivery of MCC | 7.5d | 2012-03-18 | 2012-03-24 | 1.3.2.1.040 FS+200d | 132.75d | 0d | SSH-Procurement Manhours | 2,823,800 |  |
| 1.3.2.1.060 |  | Provision of startup spare parts & Non-material-req'ts | 6d | 2012-03-25 | 2012-03-29 | 1.3.2.1.050 | 132.75d | 94.75d | SSH-Procurement Manhours | 806,800 | 0.0345614171 |
|  | 2 | **Package Substations** |  | 2011-07-09 | 2012-04-26 |  |  |  |  |  |  |
|  | 1 | **Package Substations** |  | 2011-07-09 | 2012-04-25 |  |  |  |  |  |  |
| 1.3.2.2.1.010 |  | Place PO for package substations | 37.5d | 2011-07-09 | 2011-08-11 | 1.3.2.1.010 SS | 19.25d | 0d | SSH-Procurement Manhours | 265,000 |  |
| 1.3.2.2.1.020 |  | Delivery of package substations | 7.5d | 2012-04-14 | 2012-04-19 | 1.3.2.2.1.010 FS+262.5d | 40.75d | 0d | SSH-Procurement Manhours | 1,855,000 |  |
| 1.3.2.2.1.030 |  | Provision of startup spare parts & Non-material-req'ts | 6d | 2012-04-21 | 2012-04-25 | 1.3.2.2.1.020 | 40.75d | 2.5d | SSH-Procurement Manhours | 530,000 | 0.1565602653 |
|  | 2 | **RMU - Ring Main Units** |  | 2011-07-09 | 2012-04-26 |  |  |  |  |  |  |
| 1.3.2.2.2.010 |  | Place PO for RMU | 37.5d | 2011-07-09 | 2011-08-11 | 1.3.2.2.1.010 SS | 19.25d | 0d | SSH-Procurement Manhours | 2,040,000 |  |
| 1.3.2.2.2.020 |  | Delivery of RMU | 6d | 2012-04-16 | 2012-04-21 | 1.3.2.2.2.010 FS+265d | 50.5d | 0d | SSH-Procurement Manhours | 14,280,000 |  |
| 1.3.2.2.2.030 |  | Provision of startup spare parts & Non-material-req'ts | 6d | 2012-04-21 | 2012-04-26 | 1.3.2.2.2.020 | 50.5d | 12.25d | SSH-Procurement Manhours | 4,080,000 | 1.2052186464 |
|  | 3 | **Medium Voltage Cables** |  | 2011-07-09 | 2011-12-06 |  |  |  |  |  |  |
|  | 1 | **Medium Voltage Cables** |  | 2011-07-09 | 2011-12-06 |  |  |  |  |  |  |
| 1.3.2.3.010 |  | Place PO for medium voltage cables | 37.5d | 2011-07-09 | 2011-08-11 | 1.3.2.2.2.010 SS | 19.25d | 0d | SSH-Procurement Manhours | 5,455,000 |  |
| 1.3.2.3.020 |  | Delivery of medium voltage cables | 6.25d | 2011-11-26 | 2011-11-30 | 1.3.2.3.010 FS+112.5d | 37.75d | 0d | SSH-Procurement Manhours | 38,185,000 |  |
| 1.3.2.3.030 |  | Provision of startup spare parts & Non-material-req'ts | 6d | 2011-12-01 | 2011-12-06 | 1.3.2.3.020 | 37.75d | 0d | SSH-Procurement Manhours | 10,910,000 | 3.2227782921 |
|  | 4 | **Submersible Pumps (Lift Station Pumps)** |  | 2011-07-09 | 2012-05-12 |  |  |  |  |  |  |
|  | 1 | **Submersible Pumps (Lift Station Pumps)** |  | 2011-07-09 | 2012-05-12 |  |  |  |  |  |  |
| 1.3.2.4.010 |  | Place PO for Submersible pumps | 37.5d | 2011-07-09 | 2011-08-11 | 1.3.2.3.010 SS | 19.25d | 0d | SSH-Procurement Manhours | 135,000 |  |
| 1.3.2.4.020 |  | Delivery of Submersible pumps | 6d | 2012-05-01 | 2012-05-06 | 1.3.2.4.010 FS+281.25d | 89.25d | 0d | SSH-Procurement Manhours | 945,000 |  |
| 1.3.2.4.030 |  | Provision of startup spare parts & Non-material-req'ts | 6d | 2012-05-06 | 2012-05-12 | 1.3.2.4.020 | 89.25d | 59.25d | SSH-Procurement Manhours | 270,000 | 0.0797571163 |
|  | 5 | **Diesel Generators** |  | 2011-07-09 | 2012-05-06 |  |  |  |  |  |  |
|  | 1 | **Diesel Generator** |  | 2011-07-09 | 2012-05-06 |  |  |  |  |  |  |
| 1.3.2.5.010 |  | Place PO for diesel generators | 37.5d | 2011-07-09 | 2011-08-11 | 1.3.2.4.010 SS | 19.25d | 0d | SSH-Procurement Manhours | 340,000 |  |
| 1.3.2.5.020 |  | Delivery of diesel generators | 6d | 2012-04-25 | 2012-04-30 | 1.3.2.5.010 FS+275d | 133d | 0d | SSH-Procurement Manhours | 2,380,000 |  |
| 1.3.2.5.030 |  | SPDP/monthof diesel generators | 6d | 2012-04-30 | 2012-05-06 | 1.3.2.5.020 | 133d | 98d | SSH-Procurement Manhours | 680,000 | 0.2008697744 |

| ID | WBS | Activity | Duration | Start | Finish | Predecessors | Total float | Free float | Resources | Cost | QTY |
| --- | --- | --- | --- | --- | --- | --- | --- | --- | --- | --- | --- |
|  | 6 | **Transformers** |  | 2011-07-09 | 2012-05-09 |  |  |  |  |  |  |
|  | 1 | **Transformers** |  | 2011-07-09 | 2012-05-09 |  |  |  |  |  |  |
| 1.3.2.6.010 |  | Place PO for transformers | 37.5d | 2011-07-09 | 2011-08-11 | 1.3.2.5.010 SS | 19.25d | 0d | SSH-Procurement Manhours | 63,000 |  |
| 1.3.2.6.020 |  | Delivery of transformers | 6d | 2012-04-29 | 2012-05-03 | 1.3.2.6.010 FS+278.75d | 61.75d | 0d | SSH-Procurement Manhours | 441,000 |  |
| 1.3.2.6.030 |  | Provision of startup spare parts & Non-material-req'ts | 6d | 2012-05-03 | 2012-05-09 | 1.3.2.6.020 | 61.75d | 23.5d | SSH-Procurement Manhours | 126,000 | 0.0372199876 |
|  | 7 | **Miscellaneous Items** |  | 2011-07-09 | 2012-06-21 |  |  |  |  |  |  |
|  | 1 | **Circuit Breaker** |  | 2011-09-24 | 2012-06-05 |  |  |  |  |  |  |
| 1.3.2.7.1.010 |  | Place PO for circuit breaker | 37.5d | 2011-09-24 | 2011-10-27 | 1.3.2.6.010 FS+45d | 49.25d | 0d | SSH-Procurement Manhours |  |  |
| 1.3.2.7.1.020 |  | Delivery of circuit breaker | 6d | 2012-05-26 | 2012-05-30 | 1.3.2.7.1.010 FS+225d | 71.75d | 0d | SSH-Procurement Manhours | 630,000 |  |
| 1.3.2.7.1.030 |  | Provision of startup spare parts & Non-material-req'ts | 6d | 2012-05-30 | 2012-06-05 | 1.3.2.7.1.020 | 71.75d | 33.5d | SSH-Procurement Manhours |  | 0.0372199876 |
|  | 2 | **ATS - Automatic Transfer Switch** |  | 2011-07-09 | 2012-04-07 |  |  |  |  |  |  |
| 1.3.2.7.2.010 |  | Place PO for ATS | 37.5d | 2011-07-09 | 2011-08-11 | 1.3.2.6.010 SS | 19.25d | 0d | SSH-Procurement Manhours | 78,000 |  |
| 1.3.2.7.2.020 |  | Delivery of ATS | 6d | 2012-03-27 | 2012-04-01 | 1.3.2.7.2.010 FS+243.75d | 156.75d | 0d | SSH-Procurement Manhours | 546,000 |  |
| 1.3.2.7.2.030 |  | Provision of startup spare parts & Non-material-req'ts | 6d | 2012-04-01 | 2012-04-07 | 1.3.2.7.2.020 | 156.75d | 121.75d | SSH-Procurement Manhours | 156,000 | 0.0460818894 |
|  | 3 | **Switchboard** |  | 2011-10-29 | 2012-06-05 |  |  |  |  |  |  |
| 1.3.2.7.3.010 |  | Place PO for switchboards | 37.5d | 2011-10-29 | 2011-12-01 | 1.3.2.7.1.010 SS+37.5d | 49.25d | 0d | SSH-Procurement Manhours |  |  |
| 1.3.2.7.3.020 |  | Delivery of switchboards | 6d | 2012-05-26 | 2012-05-30 | 1.3.2.7.3.010 FS+187.5d | 49.25d | 0d | SSH-Procurement Manhours | 720,000 |  |
| 1.3.2.7.3.030 |  | Provision of startup spare parts & Non-material-req'ts | 6d | 2012-05-30 | 2012-06-05 | 1.3.2.7.3.020 | 49.25d | 11d | SSH-Procurement Manhours |  | 0.0425371287 |
|  | 4 | **Distribution Panel / Panel Boards** |  | 2011-08-07 | 2012-04-18 |  |  |  |  |  |  |
| 1.3.2.7.4.010 |  | Place PO for Distribution panel boards | 37.5d | 2011-08-07 | 2011-09-10 | 1.3.2.7.2.010 SS+31.25d | 56.75d | 0d | SSH-Procurement Manhours |  |  |
| 1.3.2.7.4.020 |  | Delivery of Distribution panel boards | 6d | 2012-04-08 | 2012-04-12 | 1.3.2.7.4.010 FS+225d | 111.75d | 0d | SSH-Procurement Manhours | 156,000 |  |
| 1.3.2.7.4.030 |  | Provision of startup spare parts & Non-material-req'ts | 6d | 2012-04-12 | 2012-04-18 | 1.3.2.7.4.020 | 111.75d | 73.5d | SSH-Procurement Manhours |  | 0.0092163779 |
|  | 5 | **Annunciator Panel** |  | 2011-09-05 | 2012-06-21 |  |  |  |  |  |  |
| 1.3.2.7.5.010 |  | Place PO for Annunciator panels | 37.5d | 2011-09-05 | 2011-10-09 | 1.3.2.7.4.010 SS+31.25d | 56.75d | 0d | SSH-Procurement Manhours |  |  |
| 1.3.2.7.5.020 |  | Delivery of Annunciator panels | 6d | 2012-06-11 | 2012-06-16 | 1.3.2.7.5.010 FS+262.5d | 65.5d | 0d | SSH-Procurement Manhours | 429,000 |  |
| 1.3.2.7.5.030 |  | Provision of startup spare parts & Non-material-req'ts | 6d | 2012-06-16 | 2012-06-21 | 1.3.2.7.5.020 | 65.5d | 27.25d | SSH-Procurement Manhours |  | 0.0253450392 |

| ID | WBS | Activity | Duration | Start | Finish | Predecessors | Total float | Free float | Resources | Cost | QTY |
| --- | --- | --- | --- | --- | --- | --- | --- | --- | --- | --- | --- |
|  | 6 | **Battery Bank, Battery Charger** |  | 2011-10-10 | 2012-06-21 |  |  |  |  |  |  |
| 1.3.2.7.6.010 |  | Place PO for Battery bank & charger | 37.5d | 2011-10-10 | 2011-11-13 | 1.3.2.7.5.010 SS+37.5d | 76.75d | 0d | SSH-Procurement Manhours |  |  |
| 1.3.2.7.6.020 |  | Delivery of Battery bank & charger | 6d | 2012-06-11 | 2012-06-16 | 1.3.2.7.6.010 FS+225d | 76.75d | 0d | SSH-Procurement Manhours | 237,500 |  |
| 1.3.2.7.6.030 |  | Provision of startup spare parts & Non-material-req'ts | 6d | 2012-06-16 | 2012-06-21 | 1.3.2.7.6.020 | 76.75d | 38.5d | SSH-Procurement Manhours |  | 0.0140313445 |
|  | 7 | **UPS System** |  | 2011-07-09 | 2012-04-26 |  |  |  |  |  |  |
| 1.3.2.7.6.110 |  | Place PO for UPS | 37.5d | 2011-07-09 | 2011-08-11 | 1.3.2.7.2.010 SS | 19.25d | 0d | SSH-Procurement Manhours | 20,000 |  |
| 1.3.2.7.6.120 |  | Delivery of UPS | 8.75d | 2012-04-14 | 2012-04-21 | 1.3.2.7.6.110 FS+262.5d | 133d | 0d | SSH-Procurement Manhours | 140,000 |  |
| 1.3.2.7.6.130 |  | Provision of startup spare parts & Non-material-req'ts | 6d | 2012-04-22 | 2012-04-26 | 1.3.2.7.6.120 | 133d | 11.25d | SSH-Procurement Manhours | 40,000 | 0.0118158691 |
|  | 8 | **Electrical Grounding System** |  | 2011-08-30 | 2012-01-10 |  |  |  |  |  |  |
| 1.3.2.7.7.010 |  | Place PO for Electrical grounding system & Cables | 37.5d | 2011-08-30 | 2011-10-03 | 1.3.2.7.6.110 FS+18.75d | 38d | 0d | SSH-Procurement Manhours |  |  |
| 1.3.2.7.7.020 |  | Delivery of Electrical grounding system & Cables | 6d | 2011-12-31 | 2012-01-04 | 1.3.2.7.7.010 FS+93.75d | 156.75d | 0d | SSH-Procurement Manhours | 150,000 |  |
| 1.3.2.7.7.030 |  | Provision of startup spare parts & Non-material-req'ts | 6d | 2012-01-04 | 2012-01-10 | 1.3.2.7.7.020 | 156.75d | 34.25d | SSH-Procurement Manhours |  | 0.0088619018 |
|  | 9 | **Electrical Conduits & Fittings** |  | 2011-08-30 | 2011-12-06 |  |  |  |  |  |  |
| 1.3.2.7.8.010 |  | Place PO for electrical conduits & fittings | 37.5d | 2011-08-30 | 2011-10-03 | 1.3.2.7.7.010 SS | 38d | 0d | SSH-Procurement Manhours |  |  |
| 1.3.2.7.8.020 |  | Delivery of electrical conduits & fittings | 6d | 2011-11-26 | 2011-11-30 | 1.3.2.7.8.010 FS+56.25d | 38d | 0d | SSH-Procurement Manhours | 157,500 |  |
| 1.3.2.7.8.030 |  | Provision of startup spare parts & Non-material-req'ts | 6d | 2011-11-30 | 2011-12-06 | 1.3.2.7.8.020 | 38d | 0.25d | SSH-Procurement Manhours |  | 0.0093049969 |
|  | 10 | **Fire Detection System & FACP** |  | 2011-10-04 | 2012-05-12 |  |  |  |  |  |  |
| 1.3.2.7.9.010 |  | Place PO for fire detection sytem & FACP | 37.5d | 2011-10-04 | 2011-11-07 | 1.3.2.7.8.010 SS+37.5d | 71.75d | 0d | SSH-Procurement Manhours |  |  |
| 1.3.2.7.9.020 |  | Delivery of fire detection sytem & FACP | 6d | 2012-05-01 | 2012-05-06 | 1.3.2.7.9.010 FS+187.5d | 71.75d | 0d | SSH-Procurement Manhours | 590,000 |  |
| 1.3.2.7.9.030 |  | Provision of startup spare parts & Non-material-req'ts | 6d | 2012-05-06 | 2012-05-12 | 1.3.2.7.9.020 | 71.75d | 33.75d | SSH-Procurement Manhours |  | 0.0348568138 |
|  | 3 | **COMMUNICATION WORKS** |  | 2011-07-13 | 2012-08-14 |  |  |  |  |  |  |
|  | 1 | **Fiber Optic Cables** |  | 2011-09-14 | 2012-07-19 |  |  |  |  |  |  |
|  | 1 | **Fiber Optic Cables** |  | 2011-09-14 | 2012-04-22 |  |  |  |  |  |  |
| 1.3.3.1.1.010 |  | Place PO for fiber optic cables | 37.5d | 2011-09-14 | 2011-10-18 | 1.2.6.040 FS+10d, 1.3.2.7.5.010 SS+10d | 56.75d | 0d | SSH-Procurement Manhours |  |  |
| 1.3.3.1.1.020 |  | Delivery of fiber optic cables | 6d | 2012-04-11 | 2012-04-16 | 1.3.3.1.1.010 FS+187.5d | 59.25d | 0d | SSH-Procurement Manhours | 4,363,000 |  |
| 1.3.3.1.1.030 |  | Provision of startup spare parts & Non-material-req'ts | 6d | 2012-04-16 | 2012-04-22 | 1.3.3.1.1.020 | 59.25d | 0d | SSH-Procurement Manhours |  | 0.0268811022 |

| ID | WBS | Activity | Duration | Start | Finish | Predecessors | Total float | Free float | Resources | Cost | QTY |
| --- | --- | --- | --- | --- | --- | --- | --- | --- | --- | --- | --- |
|  | 2 | **Patch Panels** |  | 2011-10-19 | 2012-07-01 |  |  |  |  |  |  |
| 1.3.3.1.2.010 |  | Place PO for fiber optic patch panels | 37.5d | 2011-10-19 | 2011-11-22 | 1.3.3.1.1.010 SS+37.5d | 56.75d | 0d | SSH-Procurement Manhours |  |  |
| 1.3.3.1.2.020 |  | Delivery of fiber optic patch panels | 6d | 2012-06-20 | 2012-06-25 | 1.3.3.1.2.010 FS+225d | 69.25d | 0d | SSH-Procurement Manhours | 220,000 |  |
| 1.3.3.1.2.030 |  | Provision of startup spare parts & Non-material-req'ts | 6d | 2012-06-25 | 2012-07-01 | 1.3.3.1.2.020 | 69.25d | 0d | SSH-Procurement Manhours |  | 0.0070895214 |
|  | 3 | **Splice Enclosure** |  | 2011-11-12 | 2012-07-19 |  |  |  |  |  |  |
| 1.3.3.1.3.010 |  | Place PO for fiber optic splice closure | 37.5d | 2011-11-12 | 2011-12-15 | 1.3.3.1.2.010 SS+25d | 56.75d | 0d | SSH-Procurement Manhours |  |  |
| 1.3.3.1.3.020 |  | Delivery of fiber optic splice closure | 6d | 2012-07-09 | 2012-07-14 | 1.3.3.1.3.010 FS+220d | 69.25d | 0d | SSH-Procurement Manhours | 275,000 |  |
| 1.3.3.1.3.030 |  | Provision of startup spare parts & Non-material-req'ts | 6d | 2012-07-14 | 2012-07-19 | 1.3.3.1.3.020 | 69.25d | 0d | SSH-Procurement Manhours |  | 0.01624682 |
|  | 4 | **Copper Cables** |  | 2011-11-12 | 2012-07-19 |  |  |  |  |  |  |
| 1.3.3.1.4.010 |  | Place PO for copper cables | 37.5d | 2011-11-12 | 2011-12-15 | 1.3.3.1.3.010 SS | 56.75d | 0d | SSH-Procurement Manhours |  |  |
| 1.3.3.1.4.020 |  | Delivery of copper cables | 6d | 2012-07-09 | 2012-07-14 | 1.3.3.1.4.010 FS+220d | 56.75d | 0d | SSH-Procurement Manhours | 4,642,000 |  |
| 1.3.3.1.4.030 |  | Provision of startup spare parts & Non-material-req'ts | 6d | 2012-07-14 | 2012-07-19 | 1.3.3.1.4.020 | 56.75d | 0d | SSH-Procurement Manhours |  | 0.5110363378 |
|  | 2 | **Communication Duct bank systems** |  | 2011-07-13 | 2012-06-25 |  |  |  |  |  |  |
|  | 1 | **Comm Duct & Sub-duct Conduits & Fittings** |  | 2011-07-13 | 2012-01-15 |  |  |  |  |  |  |
| 1.3.3.2.1.010 |  | Place PO for comm duct & subduct conduits & fittings | 37.5d | 2011-07-13 | 2011-08-16 | 1.3.2.7.6.110 SS+5d | 19.25d | 0d | SSH-Procurement Manhours |  |  |
| 1.3.3.2.1.020 |  | Delivery of comm duct & subduct conduits & fittings | 6d | 2012-01-04 | 2012-01-09 | 1.3.3.2.1.010 FS+150d | 88d | 0d | SSH-Procurement Manhours | 525,000 |  |
| 1.3.3.2.1.030 |  | Provision of startup spare parts & Non-material-req'ts | 6d | 2012-01-09 | 2012-01-15 | 1.3.3.2.1.020 | 88d | 0d | SSH-Procurement Manhours |  | 0.0310166563 |
|  | 2 | **Communication Cabinet & Accs** |  | 2011-07-31 | 2012-03-07 |  |  |  |  |  |  |
| 1.3.3.2.1.110 |  | Place PO for comm cabinet & accs | 37.5d | 2011-07-31 | 2011-09-03 | 1.3.3.2.1.010 SS+18.75d | 19.25d | 0d | SSH-Procurement Manhours |  |  |
| 1.3.3.2.1.120 |  | Delivery of comm cabinet & accs | 6d | 2012-02-26 | 2012-03-01 | 1.3.3.2.1.110 FS+187.5d | 91.75d | 0d | SSH-Procurement Manhours | 500,000 |  |
| 1.3.3.2.1.130 |  | Provision of startup spare parts & Non-material-req'ts | 6d | 2012-03-01 | 2012-03-07 | 1.3.3.2.1.120 | 91.75d | 40.25d | SSH-Procurement Manhours |  | 0.0295396727 |
|  | 3 | **Comm Cable Trays** |  | 2011-08-07 | 2012-03-03 |  |  |  |  |  |  |
| 1.3.3.2.2.010 |  | Place PO for cable trays | 25d | 2011-08-07 | 2011-08-29 | 1.3.2.7.6.110 SS+31.25d | 66.75d | 0d | SSH-Procurement Manhours |  |  |
| 1.3.3.2.2.020 |  | Delivery of cabel trays | 6d | 2012-02-21 | 2012-02-26 | 1.3.3.2.2.010 FS+187.5d | 66.75d | 0d | SSH-Procurement Manhours | 600,000 |  |
| 1.3.3.2.2.030 |  | Material receiving inspection & approval | 6d | 2012-02-26 | 2012-03-03 | 1.3.3.2.2.020 | 66.75d | 15.25d | SSH-Procurement Manhours |  | 0.0354476072 |

| ID | WBS | Activity | Duration | Start | Finish | Predecessors | Total float | Free float | Resources | Cost | QTY |
| --- | --- | --- | --- | --- | --- | --- | --- | --- | --- | --- | --- |
|  | 4 | **Telecomm Equipments** |  | 2011-08-30 | 2012-04-07 |  |  |  |  |  |  |
| 1.3.3.2.2.110 |  | Place PO for Telecfomm equipments | 37.5d | 2011-08-30 | 2011-10-03 | 1.3.3.2.1.110 SS+32.5d | 19.25d | 0d | SSH-Procurement Manhours |  |  |
| 1.3.3.2.2.120 |  | Delivery of telecomm equipments | 6d | 2012-03-27 | 2012-04-01 | 1.3.3.2.2.110 FS+187.5d | 104.25d | 0d | SSH-Procurement Manhours | 700,000 |  |
| 1.3.3.2.2.130 |  | Material receiving inspection & approval | 6d | 2012-04-01 | 2012-04-07 | 1.3.3.2.2.120 | 104.25d | 52.75d | SSH-Procurement Manhours |  | 0.0413555418 |
|  | 5 | **Comm FOC [Fiber Optic Cable] Manholes** |  | 2011-07-13 | 2012-01-15 |  |  |  |  |  |  |
| 1.3.3.2.3.010 |  | Place PO for FOC Manholes | 37.5d | 2011-07-13 | 2011-08-16 | 1.3.2.7.6.110 SS+5d | 64.25d | 0d |  |  |  |
| 1.3.3.2.3.020 |  | Delivery of comm manhole materials | 6.25d | 2012-01-04 | 2012-01-09 | 1.3.3.2.3.010 FS+150d | 132.75d | 0d | SSH-Procurement Manhours |  |  |
| 1.3.3.2.3.030 |  | Material receiving inspection & approval | 6d | 2012-01-10 | 2012-01-15 | 1.3.3.2.3.020 | 132.75d | 37.25d | SSH-Procurement Manhours | 1,010,000 |  |
|  | 6 | **Comm Copper Cable Manholes** |  | 2011-07-13 | 2012-02-19 |  |  |  |  |  |  |
| 1.3.3.2.4.010 |  | Place PO for Copper cable Manholes | 37.5d | 2011-07-13 | 2011-08-16 | 1.3.3.2.3.010 SS | 64.25d | 0d |  |  |  |
| 1.3.3.2.4.020 |  | Delivery of comm copper cable manhole materials | 6d | 2012-02-08 | 2012-02-13 | 1.3.3.2.4.010 FS+187.5d | 95.5d | 0d | SSH-Procurement Manhours |  |  |
| 1.3.3.2.4.030 |  | Material receiving inspection & approval | 6d | 2012-02-13 | 2012-02-19 | 1.3.3.2.4.020 | 95.5d | 0d | SSH-Procurement Manhours | 852,500 |  |
|  | 7 | **Comm Copper Cable Closure** |  | 2011-08-30 | 2012-05-02 |  |  |  |  |  |  |
| 1.3.3.2.5.010 |  | Place PO for comm copper cable closure | 27.5d | 2011-08-30 | 2011-09-24 | 1.3.3.2.2.110 SS | 19.25d | 0d | SSH-Procurement Manhours |  |  |
| 1.3.3.2.5.020 |  | Delivery of comm copper cable closure | 6d | 2012-04-22 | 2012-04-26 | 1.3.3.2.5.010 FS+225d | 153d | 0d | SSH-Procurement Manhours | 160,000 |  |
| 1.3.3.2.5.030 |  | Provision of startup spare parts & Non-material-req'ts | 6d | 2012-04-26 | 2012-05-02 | 1.3.3.2.5.020 | 153d | 83.75d | SSH-Procurement Manhours |  | 0.0094526953 |
|  | 8 | **Comm Grounding System** |  | 2011-09-08 | 2012-06-25 |  |  |  |  |  |  |
| 1.3.3.2.6.010 |  | Place PO for comm grounding system | 37.5d | 2011-09-08 | 2011-10-12 | 1.3.3.2.5.010 SS+10d | 19.25d | 0d | SSH-Procurement Manhours |  |  |
| 1.3.3.2.6.020 |  | Delivery of comm grounding system | 6d | 2012-06-14 | 2012-06-19 | 1.3.3.2.6.010 FS+262.5d | 150.5d | 0d | SSH-Procurement Manhours | 52,500 |  |
| 1.3.3.2.6.030 |  | Provision of startup spare parts & Non-material-req'ts | 6d | 2012-06-19 | 2012-06-25 | 1.3.3.2.6.020 | 150.5d | 0d | SSH-Procurement Manhours |  | 0.0031016656 |
|  | 9 | **Comm Concrete Ductbank Materials** |  | 2011-07-19 | 2011-12-17 |  |  |  |  |  |  |
| 1.3.3.2.7.010 |  | Place PO for comm concrete ductbank materials | 37.5d | 2011-07-19 | 2011-08-22 | 1.3.3.2.4.010 SS+6.25d | 64.25d | 0d |  |  |  |
| 1.3.3.2.7.020 |  | Delivery of comm ductbank materials | 6d | 2011-12-06 | 2011-12-11 | 1.3.3.2.7.010 SS+150d | 176.75d | 0d | SSH-Procurement Manhours |  |  |
| 1.3.3.2.7.030 |  | Material receiving inspection & approval | 6d | 2011-12-11 | 2011-12-17 | 1.3.3.2.7.020 | 176.75d | 81.25d | SSH-Procurement Manhours | 1,950,000 |  |

| ID | WBS | Activity | Duration | Start | Finish | Predecessors | Total float | Free float | Resources | Cost | QTY |
| --- | --- | --- | --- | --- | --- | --- | --- | --- | --- | --- | --- |
|  | 10 | **Electrical Ductbank Materials** |  | 2011-07-19 | 2011-11-12 |  |  |  |  |  |  |
| 1.3.3.2.8.010 |  | Place PO for comm electrical ductbank materials | 37.5d | 2011-07-19 | 2011-08-22 | 1.3.3.2.7.010 SS | 64.25d | 0d |  |  |  |
| 1.3.3.2.8.020 |  | Delivery of electrical ductbank materials | 6d | 2011-11-01 | 2011-11-06 | 1.3.3.2.8.010 SS+112.5d | 64.25d | 0d | SSH-Procurement Manhours |  |  |
| 1.3.3.2.8.030 |  | Material receiving inspection & approval | 6d | 2011-11-06 | 2011-11-12 | 1.3.3.2.8.020 | 64.25d | 26.5d | SSH-Procurement Manhours | 1,950,000 |  |
|  | 3 | **Miscellaneous Communication Items** |  | 2011-09-24 | 2012-08-14 |  |  |  |  |  |  |
|  | 1 | **Communication CCTV System** |  | 2011-09-24 | 2012-06-05 |  |  |  |  |  |  |
| 1.3.3.3.010 |  | Place PO for CCTV system materials | 37.5d | 2011-09-24 | 2011-10-27 | 1.3.3.2.6.010 SS+16.25d | 19.25d | 0d | SSH-Procurement Manhours |  |  |
| 1.3.3.3.020 |  | Delivery of CCTV system materials | 6d | 2012-05-26 | 2012-05-30 | 1.3.3.3.010 FS+225d | 75.5d | 0d | SSH-Procurement Manhours | 725,000 |  |
| 1.3.3.3.030 |  | Provision of startup spare parts & Non-material-req'ts | 6d | 2012-05-30 | 2012-06-05 | 1.3.3.3.020 | 75.5d | 24d | SSH-Procurement Manhours |  | 0.0428325254 |
|  | 2 | **Communication SACS System** |  | 2011-10-29 | 2012-08-14 |  |  |  |  |  |  |
| 1.3.3.3.110 |  | Place PO for Comm SACS System | 37.5d | 2011-10-29 | 2011-12-01 | 1.3.3.3.010 SS+37.5d | 69d | 0d | SSH-Procurement Manhours |  |  |
| 1.3.3.3.120 |  | Delivery of comm SACS system | 6.25d | 2012-08-04 | 2012-08-08 | 1.3.3.3.110 FS+262.5d | 69d | 0d | SSH-Procurement Manhours | 725,000 |  |
| 1.3.3.3.130 |  | Provision of startup spare parts & Non-material-req'ts | 6d | 2012-08-09 | 2012-08-14 | 1.3.3.3.120 | 69d | 0d | SSH-Procurement Manhours |  | 0.0428325254 |
|  | 4 | **LANDSCAPING WORKS** |  | 2011-09-24 | 2012-06-14 |  |  |  |  |  |  |
|  | 1 | **Landscaping & Playground Materials** |  | 2011-09-24 | 2012-06-14 |  |  |  |  |  |  |
|  | 1 | **Landscaping Materials** |  | 2011-09-24 | 2012-03-27 |  |  |  |  |  |  |
| 1.3.4.1.010 |  | Place PO for trees/shrubs/ground covers | 37.5d | 2011-09-24 | 2011-10-27 | 1.3.3.3.010 SS | 19.25d | 0d | SSH-Procurement Manhours |  |  |
| 1.3.4.1.020 |  | Delivery of trees/shrubs/ground covers | 6d | 2012-03-17 | 2012-03-21 | 1.3.4.1.010 FS+150d | 19.25d | 0d | SSH-Procurement Manhours | 2,950,000 |  |
| 1.3.4.1.030 |  | Material receiving inspection & approval | 6d | 2012-03-21 | 2012-03-27 | 1.3.4.1.020 | 19.25d | 9.25d | SSH-Procurement Manhours |  | 0.1181586908 |
|  | 2 | **Playground Materials** |  | 2011-10-03 | 2012-06-14 |  |  |  |  |  |  |
| 1.3.4.1.110 |  | Place PO for playground utilities | 37.5d | 2011-10-03 | 2011-11-06 | 1.3.4.1.010 SS+10d | 67.75d | 0d | SSH-Procurement Manhours |  |  |
| 1.3.4.1.120 |  | Delivery of playground utilities | 6.25d | 2012-06-04 | 2012-06-09 | 1.3.4.1.110 FS+225d | 67.75d | 0d | SSH-Procurement Manhours | 1,100,000 |  |
| 1.3.4.1.130 |  | Provision of startup spare parts & Non-material-req'ts | 6d | 2012-06-10 | 2012-06-14 | 1.3.4.1.120 | 67.75d | 57.75d | SSH-Procurement Manhours |  | 0.1211126581 |
|  | 5 | **UTILITIES & SERVICE WORKS** |  | 2011-06-25 | 2012-07-28 |  |  |  |  |  |  |
|  | 1 | **Potable & Fire Water Pipelines & Fittings** |  | 2011-07-16 | 2012-07-28 |  |  |  |  |  |  |
|  | 2 | **Potable / Fire water /Sewer Pipes (RTR) & Fittings** |  | 2011-07-16 | 2011-12-06 |  |  |  |  |  |  |
| 1.3.5.1.2.010 |  | Place PO for potable / fire water /sewer pipe (RTR) | 30d | 2011-07-16 | 2011-08-11 | 1.3.2.1.010 SS+7.5d | 25d | 0d | SSH-Procurement Manhours | 1,267,500 |  |
| 1.3.5.1.2.020 |  | Delivery of RTR & fittings | 6d | 2011-11-26 | 2011-11-30 | 1.3.5.1.2.010 FS+112.5d | 104.25d | 0d | SSH-Procurement Manhours | 8,872,500 |  |
| 1.3.5.1.2.030 |  | Provision of startup spare parts & Non-material-req'ts | 6d | 2011-11-30 | 2011-12-06 | 1.3.5.1.2.020 | 104.25d | 66.75d | SSH-Procurement Manhours | 2,535,000 | 0.7488307031 |

| ID | WBS | Activity | Duration | Start | Finish | Predecessors | Total float | Free float | Resources | Cost | QTY |
| --- | --- | --- | --- | --- | --- | --- | --- | --- | --- | --- | --- |
|  | 3 | **Potable & Fire water valves & accs** |  | 2011-07-20 | 2012-04-01 |  |  |  |  |  |  |
| 1.3.5.1.3.010 |  | Place PO for potable & fire water valves | 37.5d | 2011-07-20 | 2011-08-23 | 1.3.5.1.2.010 SS+5d | 38d | 0d | SSH-Procurement Manhours |  |  |
| 1.3.5.1.3.020 |  | Delivery of valves & accs | 6d | 2012-03-21 | 2012-03-26 | 1.3.5.1.3.010 FS+225d | 158d | 0d | SSH-Procurement Manhours | 3,049,000 |  |
| 1.3.5.1.3.030 |  | Provision of startup spare parts & Non-material-req'ts | 6d | 2012-03-26 | 2012-04-01 | 1.3.5.1.3.020 | 158d | 37.5d | SSH-Procurement Manhours |  | 0.1801329242 |
|  | 4 | **Fire Hydrants & Accs** |  | 2011-12-19 | 2012-07-28 |  |  |  |  |  |  |
| 1.3.5.1.3.040 |  | Place PO for fire hydrants & accs | 37.5d | 2011-12-19 | 2012-01-22 | 1.3.5.1.3.010 FS+125d | 63d | 0d | SSH-Procurement Manhours |  |  |
| 1.3.5.1.3.050 |  | Delivery of fire hydranst | 6d | 2012-07-17 | 2012-07-22 | 1.3.5.1.3.040 FS+188.75d | 63d | 0d | SSH-Procurement Manhours | 476,000 |  |
| 1.3.5.1.3.060 |  | Provision of startup spare parts & Non-material-req'ts | 6d | 2012-07-22 | 2012-07-28 | 1.3.5.1.3.050 | 63d | 0d | SSH-Procurement Manhours |  | 0.0281217684 |
|  | 2 | **Sanitary Sewer Pipeline & Related Equipments** |  | 2011-07-16 | 2012-05-06 |  |  |  |  |  |  |
|  | 1 | **Sewer FRP Manholes** |  | 2011-07-16 | 2011-09-20 |  |  |  |  |  |  |
| 1.3.5.2.1.010 |  | Place PO for sewer FRP Manhole | 28.75d | 2011-07-16 | 2011-08-10 | 1.3.5.1.2.010 SS | 25d | 0d | SSH-Procurement Manhours | 120,000 |  |
| 1.3.5.2.1.020 |  | Delivery of sewer FRP Manhole | 3.75d | 2011-09-12 | 2011-09-14 | 1.3.5.2.1.010 FS+33.75d | 45.25d | 0d | SSH-Procurement Manhours | 840,000 |  |
| 1.3.5.2.1.030 |  | Provision of startup spare parts & Non-material-req'ts | 6d | 2011-09-15 | 2011-09-20 | 1.3.5.2.1.020 | 45.25d | 7.75d | SSH-Procurement Manhours | 240,000 | 0.0708952145 |
|  | 2 | **Sewer pipes (uPVC) & Fittings** |  | 2011-07-16 | 2011-09-20 |  |  |  |  |  |  |
| 1.3.5.2.2.010 |  | Place PO for sewer (uPVC) pipes | 33.75d | 2011-07-16 | 2011-08-15 | 1.3.5.1.2.010 SS | 76.5d | 0d | SSH-Procurement Manhours |  |  |
| 1.3.5.2.2.020 |  | Delivery of sewer (uPVC) pipes | 2.5d | 2011-09-13 | 2011-09-14 | 1.3.5.2.2.010 FS+30d | 76.5d | 0d | SSH-Procurement Manhours | 890,000 |  |
| 1.3.5.2.2.030 |  | Provision of startup spare parts & Non-material-req'ts | 6d | 2011-09-15 | 2011-09-20 | 1.3.5.2.2.020 | 76.5d | 39d | SSH-Procurement Manhours |  | 0.0525806174 |
|  | 3 | **Plumbing Fixtures & Accs** |  | 2011-07-30 | 2012-01-31 |  |  |  |  |  |  |
| 1.3.5.2.3.010 |  | Place PO for Plumbing fixtures & accs | 37.5d | 2011-07-30 | 2011-09-01 | 1.3.5.1.3.010 SS+10d | 38d | 0d | SSH-Procurement Manhours |  |  |
| 1.3.5.2.3.020 |  | Delivery of Plumbing fixtures & accs | 6d | 2012-01-21 | 2012-01-25 | 1.3.5.2.3.010 FS+150d | 38d | 0d | SSH-Procurement Manhours | 850,000 |  |
| 1.3.5.2.3.030 |  | Provision of startup spare parts & Non-material-req'ts | 6d | 2012-01-25 | 2012-01-31 | 1.3.5.2.3.020 | 38d | 0d | SSH-Procurement Manhours |  | 0.0443095091 |
|  | 4 | **Sewer pipes valve & accs** |  | 2011-07-30 | 2012-05-06 |  |  |  |  |  |  |
| 1.3.5.2.4.010 |  | Place PO for sewer valves & accs | 27.5d | 2011-07-30 | 2011-08-23 | 1.3.5.2.3.010 SS | 71.75d | 0d | SSH-Procurement Manhours |  |  |
| 1.3.5.2.4.020 |  | Delivery of sewer valves & accs | 6d | 2012-04-25 | 2012-04-30 | 1.3.5.2.4.010 FS+262.5d | 71.75d | 0d | SSH-Procurement Manhours | 290,000 |  |
| 1.3.5.2.4.030 |  | Provision of startup spare parts & Non-material-req'ts | 6d | 2012-04-30 | 2012-05-06 | 1.3.5.2.4.020 | 71.75d | 34.25d | SSH-Procurement Manhours |  | 0.0171330102 |

| ID | WBS | Activity | Duration | Start | Finish | Predecessors | Total float | Free float | Resources | Cost | QTY |
| --- | --- | --- | --- | --- | --- | --- | --- | --- | --- | --- | --- |
|  | 5 | **Sewer - odour control system** |  | 2011-07-16 | 2012-04-24 |  |  |  |  |  |  |
| 1.3.5.2.5.010 |  | Place PO for sewer odour control system | 30d | 2011-07-16 | 2011-08-11 | 1.3.5.2.1.010 SS | 25d | 0d | SSH-Procurement Manhours | 134,500 |  |
| 1.3.5.2.5.020 |  | Delivery of sewer odour control system | 6d | 2012-04-14 | 2012-04-18 | 1.3.5.2.5.010 FS+262.5d | 94.25d | 0d | SSH-Procurement Manhours | 941,500 |  |
| 1.3.5.2.5.030 |  | Provision of startup spare parts & Non-material-req'ts | 6d | 2012-04-18 | 2012-04-24 | 1.3.5.2.5.020 | 94.25d | 38.25d | SSH-Procurement Manhours | 269,000 | 0.1149093268 |
|  | 6 | **Ductile Iron pipes & Fittings** |  | 2011-09-28 | 2012-04-26 |  |  |  |  |  |  |
| 1.3.5.2.6.010 |  | Place PO for ductile iron pipes & fittings | 30d | 2011-09-28 | 2011-10-25 | 1.3.5.2.5.010 FS+50d | 91.5d | 0d | SSH-Procurement Manhours |  |  |
| 1.3.5.2.6.020 |  | Delivery of ductile iron pipes & fittings | 3.75d | 2012-04-18 | 2012-04-21 | 1.3.5.2.6.010 FS+187.5d | 91.5d | 0d | SSH-Procurement Manhours | 500,000 |  |
| 1.3.5.2.6.030 |  | Provision of startup spare parts & Non-material-req'ts | 6d | 2012-04-22 | 2012-04-26 | 1.3.5.2.6.020 | 91.5d | 35.5d | SSH-Procurement Manhours |  | 0.1149093268 |
|  | 3 | **Irrigation Pipeline & related equipments** |  | 2011-07-16 | 2012-05-09 |  |  |  |  |  |  |
|  | 1 | **Irrigation pipeline & fittings** |  | 2011-07-16 | 2012-01-19 |  |  |  |  |  |  |
| 1.3.5.3.1.010 |  | Place PO for irrigation pipeline & fittings | 40d | 2011-07-16 | 2011-08-21 | 1.3.5.2.5.010 SS | 25d | 0d | SSH-Procurement Manhours |  |  |
| 1.3.5.3.1.020 |  | Delivery of irrigation pipeline & fittings | 6d | 2012-01-09 | 2012-01-14 | 1.3.5.3.1.010 FS+150d | 56.75d | 0d | SSH-Procurement Manhours | 1,778,000 |  |
| 1.3.5.3.1.030 |  | Provision of startup spare parts & Non-material-req'ts | 6d | 2012-01-14 | 2012-01-19 | 1.3.5.3.1.020 | 56.75d | 19.25d | SSH-Procurement Manhours |  | 0.0354476072 |
|  | 2 | **Irrigation valves & accs** |  | 2011-07-27 | 2012-05-06 |  |  |  |  |  |  |
| 1.3.5.3.2.010 |  | Place PO for irrigation valves & accs | 30d | 2011-07-27 | 2011-08-23 | 1.3.5.3.1.010 SS+12.5d | 25d | 0d | SSH-Procurement Manhours |  |  |
| 1.3.5.3.2.020 |  | Delivery of irrigation valves & accs | 6d | 2012-04-25 | 2012-04-30 | 1.3.5.3.2.010 FS+262.5d | 120.5d | 0d | SSH-Procurement Manhours | 852,000 |  |
| 1.3.5.3.2.030 |  | Provision of startup spare parts & Non-material-req'ts | 6d | 2012-04-30 | 2012-05-06 | 1.3.5.3.2.020 | 120.5d | 0d | SSH-Procurement Manhours |  | 0.1199310712 |
|  | 3 | **Irrigation controllers** |  | 2011-09-01 | 2012-05-09 |  |  |  |  |  |  |
| 1.3.5.3.3.010 |  | Place PO for irrigation controllers | 30d | 2011-09-01 | 2011-09-28 | 1.3.5.3.2.010 SS+38.75d | 25d | 0d | SSH-Procurement Manhours |  |  |
| 1.3.5.3.3.020 |  | Delivery of irrigation controllers | 8d | 2012-04-26 | 2012-05-03 | 1.3.5.3.3.010 FS+225d | 36d | 0d | SSH-Procurement Manhours | 325,000 |  |
| 1.3.5.3.3.030 |  | Provision of startup spare parts & Non-material-req'ts | 6d | 2012-05-03 | 2012-05-09 | 1.3.5.3.3.020 | 36d | 26d | SSH-Procurement Manhours |  | 0.0192007873 |
|  | 4 | **Irrigation Junction Boxes** |  | 2011-09-25 | 2012-04-26 |  |  |  |  |  |  |
| 1.3.5.3.4.010 |  | Place PO for irrigation junction boxes | 30d | 2011-09-25 | 2011-10-22 | 1.3.5.3.3.010 SS+25d | 49.75d | 0d | SSH-Procurement Manhours |  |  |
| 1.3.5.3.4.020 |  | Delivery of irrigation junction boxes | 8d | 2012-04-14 | 2012-04-21 | 1.3.5.3.4.010 FS+186.25d | 49.75d | 0d | SSH-Procurement Manhours | 565,000 |  |
| 1.3.5.3.4.030 |  | Provision of startup spare parts & Non-material-req'ts | 6d | 2012-04-21 | 2012-04-26 | 1.3.5.3.4.020 | 49.75d | 39.75d | SSH-Procurement Manhours |  | 0.0333798302 |

| ID | WBS | Activity | Duration | Start | Finish | Predecessors | Total float | Free float | Resources | Cost | QTY |
| --- | --- | --- | --- | --- | --- | --- | --- | --- | --- | --- | --- |
|  | 4 | **Street Lighting Network & Related Equipments** |  | 2011-06-25 | 2012-05-13 |  |  |  |  |  |  |
|  | 01 | **Street Lighting Poles (For Patrol Roads)** |  | 2011-06-25 | 2011-08-14 |  |  |  |  |  |  |
| 1.3.5.4.1.010 |  | Place PO for street lighting poles (Patrol Roads) | 7.5d | 2011-06-25 | 2011-06-30 | 1.3.1.6.130 FS+100d | 59d | 0d | SSH-Procurement Manhours |  |  |
| 1.3.5.4.1.020 |  | Delivery of street lighting poles (Patrol Roads) | 6d | 2011-08-06 | 2011-08-10 | 1.3.5.4.1.010 FS+37.5d | 101.5d | 0d | SSH-Procurement Manhours | 1,903,200 |  |
| 1.3.5.4.1.030 |  | Provision of startup spare parts & Non-material-req'ts | 3.75d | 2011-08-10 | 2011-08-14 | 1.3.5.4.1.020 | 101.5d | 0d | SSH-Procurement Manhours |  | 0.3747993673 |
|  | 02 | **Street Lighting Fixtures (For Patrol Roads)** |  | 2011-06-25 | 2011-08-13 |  |  |  |  |  |  |
| 1.3.5.4.2.010 |  | Place PO for street lighting fixtures (Patrol Roads) | 7.5d | 2011-06-25 | 2011-06-30 | 1.3.5.4.1.010 SS | 59d | 0d | SSH-Procurement Manhours |  |  |
| 1.3.5.4.2.020 |  | Delivery of street lighting fixtures (Patrol Roads) | 5d | 2011-08-06 | 2011-08-09 | 1.3.5.4.2.010 FS+37.5d | 102.5d | 0d | SSH-Procurement Manhours | 658,800 |  |
| 1.3.5.4.2.030 |  | Provision of startup spare parts & Non-material-req'ts | 3.75d | 2011-08-10 | 2011-08-13 | 1.3.5.4.2.020 | 102.5d | 1d | SSH-Procurement Manhours |  | 0.1297382425 |
|  | 03 | **LV Cables (For Patrol Roads)** |  | 2011-06-25 | 2011-08-10 |  |  |  |  |  |  |
| 1.3.5.4.3.010 |  | Place PO for LV cables (Patrol Roads) | 5d | 2011-06-25 | 2011-06-28 | 1.3.5.4.2.010 SS | 59d | 0d | SSH-Procurement Manhours |  |  |
| 1.3.5.4.3.020 |  | Delivery of LV cables (Patrol Roads) | 5d | 2011-08-03 | 2011-08-07 | 1.3.5.4.3.010 FS+37.5d | 105d | 0d | SSH-Procurement Manhours | 1,917,858 |  |
| 1.3.5.4.3.030 |  | Provision of startup spare parts & Non-material-req'ts | 3.75d | 2011-08-08 | 2011-08-10 | 1.3.5.4.3.020 | 105d | 3.5d | SSH-Procurement Manhours |  | 0.3776859841 |
|  | 04 | **Street Light Poles (For Permanent Roads)** |  | 2011-09-11 | 2012-04-12 |  |  |  |  |  |  |
| 1.3.5.4.4.010 |  | Place PO for Light Poles (Permanent Roads) | 30d | 2011-09-11 | 2011-10-08 | 1.4.5.4.6.010 SS+10d | 76.25d | 0d | SSH-Procurement Manhours |  |  |
| 1.3.5.4.4.020 |  | Delivery of Light Poles (Permenent Roads) | 7.5d | 2012-03-31 | 2012-04-05 | 1.3.5.4.4.010 FS+186.25d | 83.75d | 0d | SSH-Procurement Manhours | 4,440,800 |  |
| 1.3.5.4.4.030 |  | Provision of startup spare parts & Non-material-req'ts | 7.5d | 2012-04-07 | 2012-04-12 | 1.3.5.4.4.020 | 83.75d | 58.75d | SSH-Procurement Manhours |  |  |
|  | 05 | **Street Light Fixtures (For Permenent Roads)** |  | 2011-09-11 | 2012-04-19 |  |  |  |  |  |  |
| 1.4.5.4.5.010 |  | Place PO for Light Fixtures (Permanent Roads) | 37.5d | 2011-09-11 | 2011-10-15 | 1.3.5.4.4.010 SS | 76.25d | 0d | SSH-Procurement Manhours |  |  |
| 1.4.5.4.5.020 |  | Delivery of Light Fixtures (Permanent Roads) | 7.5d | 2012-04-07 | 2012-04-12 | 1.4.5.4.5.010 FS+186.25d | 76.25d | 0d | SSH-Procurement Manhours | 1,537,200 |  |
| 1.4.5.4.5.030 |  | Provision of startup spare parts & Non-material-req'ts | 7.5d | 2012-04-14 | 2012-04-19 | 1.4.5.4.5.020 | 76.25d | 51.25d | SSH-Procurement Manhours |  |  |
|  | 06 | **LV Cables (For Permanent Roads)** |  | 2011-09-01 | 2012-02-22 |  |  |  |  |  |  |
| 1.4.5.4.6.010 |  | Place PO for LV cables (Permanent Roads) | 30d | 2011-09-01 | 2011-09-28 | 1.3.5.3.3.010 SS | 25d | 0d | SSH-Procurement Manhours |  |  |
| 1.4.5.4.6.020 |  | Delivery of LV Cables (Permanent Roads) | 7.5d | 2012-02-16 | 2012-02-22 | 1.4.5.4.6.010 FS+150d | 25d | 0d | SSH-Procurement Manhours | 4,475,002 |  |
| 1.4.5.4.6.030 |  | Provision of startup spare parts & Non-material-req'ts | 7.5d | 2012-02-16 | 2012-02-22 | 1.4.5.4.6.020 SS | 25d | 0d | SSH-Procurement Manhours |  |  |

| ID | WBS | Activity | Duration | Start | Finish | Predecessors | Total float | Free float | Resources | Cost | QTY |
| --- | --- | --- | --- | --- | --- | --- | --- | --- | --- | --- | --- |
|  | 07 | **HVAC Equipments** |  | 2011-06-25 | 2012-04-10 |  |  |  |  |  |  |
| 1.3.5.4.7.010 |  | Place PO for HVAC Equipments | 30d | 2011-06-25 | 2011-07-21 | 1.3.5.4.3.010 SS | 59d | 0d | SSH-Procurement Manhours | 69,150 |  |
| 1.3.5.4.7.020 |  | Delivery of HVAC Equipments | 10d | 2012-03-24 | 2012-04-01 | 1.3.5.4.7.010 FS+262.5d | 89.75d | 0d | SSH-Procurement Manhours | 484,050 |  |
| 1.3.5.4.7.030 |  | Provision of startup spare parts & Non-material-req'ts | 10d | 2012-04-02 | 2012-04-10 | 1.3.5.4.7.020 | 89.75d | 12.5d | SSH-Procurement Manhours | 138,300 | 0.0408533674 |
|  | 08 | **Volume & Fire Dampers** |  | 2011-07-06 | 2012-04-22 |  |  |  |  |  |  |
| 1.3.5.4.9.010 |  | Place PO for volume & fire dampers | 30d | 2011-07-06 | 2011-08-02 | 1.3.5.4.7.010 SS+12.5d | 59d | 0d | SSH-Procurement Manhours |  |  |
| 1.3.5.4.9.020 |  | Delivery of volume & fire dampers | 10d | 2012-04-04 | 2012-04-12 | 1.3.5.4.9.010 FS+262.5d | 77.25d | 0d | SSH-Procurement Manhours | 312,500 |  |
| 1.3.5.4.9.030 |  | Provision of startup spare parts & Non-material-req'ts | 10d | 2012-04-14 | 2012-04-22 | 1.3.5.4.9.020 | 77.25d | 0d | SSH-Procurement Manhours |  | 0.0184622954 |
|  | 09 | **Moduler Rectifier / Inverter** |  | 2011-07-06 | 2012-04-22 |  |  |  |  |  |  |
| 1.3.5.4.10.010 |  | Place PO for moduler rectifier / inverter | 30d | 2011-07-06 | 2011-08-02 | 1.3.5.4.9.010 SS | 59d | 0d | SSH-Procurement Manhours |  |  |
| 1.3.5.4.10.020 |  | Delivery of moduler rectifier / inverter | 10d | 2012-04-04 | 2012-04-12 | 1.3.5.4.10.010 FS+262.5d | 77.25d | 0d | SSH-Procurement Manhours | 212,500 |  |
| 1.3.5.4.10.030 |  | Provision of startup spare parts & Non-material-req'ts | 10d | 2012-04-14 | 2012-04-22 | 1.3.5.4.10.020 | 77.25d | 0d | SSH-Procurement Manhours |  | 0.0125543609 |
|  | 10 | **Exhaust Fans** |  | 2011-07-27 | 2012-05-13 |  |  |  |  |  |  |
| 1.3.5.4.10.040 |  | Place PO for exhaust fans | 30d | 2011-07-27 | 2011-08-23 | 1.3.5.4.10.010 SS+22.5d | 59d | 0d | SSH-Procurement Manhours |  |  |
| 1.3.5.4.10.050 |  | Delivery of exhasust fans | 10d | 2012-04-25 | 2012-05-03 | 1.3.5.4.10.040 FS+262.5d | 116.75d | 0d | SSH-Procurement Manhours | 400,640 |  |
| 1.3.5.4.10.060 |  | Provision of startup spare parts & Non-material-req'ts | 10d | 2012-05-05 | 2012-05-13 | 1.3.5.4.10.050 | 116.75d | 39.5d | SSH-Procurement Manhours |  | 0.0236695489 |
|  | 5 | **Fitness Shelter equipemnts & Furnitures** |  | 2011-12-08 | 2012-07-19 |  |  |  |  |  |  |
|  | 1 | **Fitness Shelter equipments & furniture** |  | 2011-12-08 | 2012-07-19 |  |  |  |  |  |  |
| 1.3.5.5.010 |  | Place PO for fitness & art shelters furniture | 37.5d | 2011-12-08 | 2012-01-11 | 1.3.5.4.10.040 FS+113.75d | 59d | 0d | SSH-Procurement Manhours |  |  |
| 1.3.5.5.020 |  | Delivery of fitness & art shelters furniture | 6d | 2012-07-05 | 2012-07-10 | 1.3.5.5.010 SS+225d | 59d | 0d | SSH-Procurement Manhours | 950,000 |  |
| 1.3.5.5.030 |  | SPDP/monthof fitness & art shelters furniture | 10d | 2012-07-10 | 2012-07-19 | 1.3.5.5.020 | 59d | 0d | SSH-Procurement Manhours |  | 0.0561253781 |
|  | C.1.4 | **CONSTRUCTION** |  | 2011-01-09 | 2013-06-29 |  |  |  |  |  |  |
|  | 1 | **MOBILIZATION** |  | 2011-01-09 | 2011-09-28 |  |  |  |  |  |  |
|  | 1 | **Mobilization** |  | 2011-01-09 | 2011-03-10 |  |  |  |  |  |  |
|  | 2 | **Mobilization of Temp. Fac. @ Zone 4** |  | 2011-01-09 | 2011-03-10 |  |  |  |  |  |  |
| 1.4.1.1.110 |  | Install of temp fence at zone 4 | 40d | 2011-01-09 | 2011-02-14 | M1.00 | 46.25d | 0d | SSH-Construction Manhours [19200 h] | 250,000 |  |
| 1.4.1.1.210 |  | Construction of contractor site offices | 40d | 2011-01-18 | 2011-02-23 | 1.4.1.1.110 SS+10d | 46.25d | 0d | SSH-Construction Manhours [19200 h] | 500,000 |  |
| 1.4.1.1.130 |  | Const/Install of laydown yards | 40d | 2011-01-20 | 2011-02-26 | 1.4.1.1.110 SS+12.5d | 117.5d | 0d | SSH-Construction Manhours [19200 h] | 500,000 |  |
| 1.4.1.1.120 |  | Construction of SAPMT office | 31.25d | 2011-02-01 | 2011-03-01 | 1.4.1.1.210 SS+15d | 127.5d | 10d | SSH-Construction Manhours [15000 h] | 750,000 |  |
| 1.4.1.1.220 |  | Mobilization of equipments | 30d | 2011-02-01 | 2011-02-28 | 1.4.1.1.130 SS+12.5d | 117.5d | 0d | SSH-Construction Manhours [19200 h] | 3,250,000 |  |
| 1.4.1.1.140 |  | Install electric lighting system for site offices | 20d | 2011-02-10 | 2011-02-28 | 1.4.1.1.210 SS+25d | 46.25d | 0d | SSH-Construction Manhours [9600 h] | 250,000 |  |
| 1.4.1.1.230 |  | Mobilization of Manpower | 31.25d | 2011-02-10 | 2011-03-10 | 1.4.1.1.220 SS+10d, 1.4.1.1.110 SS+10d | 117.5d | 0d | SSH-Construction Manhours [25000 h] | 800,000 | 0.2363173816 |
| 1.4.1.1.150 |  | Install water supply system for offices | 15d | 2011-02-22 | 2011-03-07 | 1.4.1.1.140 SS+12.5d | 46.25d | 0d | SSH-Construction Manhours [9600 h] | 100,000 |  |
| 1.4.1.1.160 |  | Install sanitary system for offices | 11.25d | 2011-02-28 | 2011-03-09 | 1.4.1.1.150 SS+6.25d | 46.25d | 0d | SSH-Construction Manhours [9000 h] | 75,000 |  |
| 1.4.1.1.170 |  | Install fire protection sytem for offices | 8.75d | 2011-03-02 | 2011-03-09 | 1.4.1.1.160 SS+2.5d | 118.75d | 0d | SSH-Construction Manhours [7000 h] | 25,000 |  |
| 1.4.1.1.180 |  | Install furniture & accs in offices | 8.75d | 2011-03-02 | 2011-03-09 | 1.4.1.1.170 SS | 118.75d | 0d | SSH-Construction Manhours [7000 h] | 125,000 |  |
| 1.4.1.1.190 |  | Install computers / equipments & accs in offices | 8.75d | 2011-03-02 | 2011-03-09 | 1.4.1.1.180 SS | 118.75d | 0d | SSH-Construction Manhours [7000 h] | 150,000 |  |
| 1.4.1.1.200 |  | Install telecomm system for offices | 8.75d | 2011-03-02 | 2011-03-09 | 1.4.1.1.190 SS | 118.75d | 57.5d | SSH-Construction Manhours [7000 h] | 75,000 |  |

| ID | WBS | Activity | Duration | Start | Finish | Predecessors | Total float | Free float | Resources | Cost | QTY |
| --- | --- | --- | --- | --- | --- | --- | --- | --- | --- | --- | --- |
|  | 2 | **Demolition of existing structure** |  | 2011-06-09 | 2011-09-28 |  |  |  |  |  |  |
|  | 1 | **Demolition of existing structure** |  | 2011-06-09 | 2011-09-28 |  |  |  |  |  |  |
|  | 1 | **Zone 2** |  | 2011-07-24 | 2011-09-17 |  |  |  |  |  |  |
| 1.4.1.2.1.010 |  | Demolition of existing laydown yard etc. | 30d | 2011-07-24 | 2011-08-20 | 1.4.1.3.2.010, M1.00 FS+15d, 1.4.1.1.120, 1.4.1.1.200 | 195d | 0d | SSH-Construction Manhours [12000 h] | 525,000 |  |
| 1.4.1.2.1.020 |  | Demolition of existing asphalt pavement | 30d | 2011-08-21 | 2011-09-17 | 1.4.1.2.1.010 | 195d | 0d | SSH-Construction Manhours [12000 h] | 655,000 | 0.1934848562 |
|  | 2 | **Zone 3** |  | 2011-06-09 | 2011-09-28 |  |  |  |  |  |  |
| 1.4.1.2.2.010 |  | Demolition of existing concrete pad/structure | 30d | 2011-06-09 | 2011-07-06 | 1.4.1.3.3.010 | 106.25d | 0d | SSH-Construction Manhours [7200 h] | 207,500 |  |
| 1.4.1.2.2.020 |  | Demolition of existing porta cabin , tank | 30d | 2011-07-07 | 2011-08-03 | 1.4.1.2.2.010 | 106.25d | 0d | SSH-Construction Manhours [16800 h] | 17,500 |  |
| 1.4.1.2.2.030 |  | Demolition of existing temporary bldgs | 30d | 2011-08-04 | 2011-08-31 | 1.4.1.2.2.020 | 106.25d | 0d | SSH-Construction Manhours [12000 h] | 1,550,000 |  |
| 1.4.1.2.2.040 |  | Demolition of existing generator shed | 30d | 2011-09-01 | 2011-09-28 | 1.4.1.2.2.030 | 106.25d | 0d | SSH-Construction Manhours [12000 h] | 45,000 | 0.0132928527 |
|  | 2 | **UTILITIES & SERVICES WORKS** |  | 2011-03-19 | 2012-12-17 |  |  |  |  |  |  |
|  | 1 | **Site Preparations** |  | 2011-04-10 | 2011-11-05 |  |  |  |  |  |  |
|  | 1 | **Site Topographic Survey & Layout** |  | 2011-05-03 | 2011-06-28 |  |  |  |  |  |  |
|  | 1 | **Site Topographic Survey & Layout** |  | 2011-05-03 | 2011-06-28 |  |  |  |  |  |  |
| 1.4.1.3.1.200 |  | Site topographic survey & survey layout & stacking | 31.25d | 2011-05-03 | 2011-05-31 | 1.4.1.3.3.010 SS+25d, M2.01, M2.02, M2.03, 1.4.1.1.200 | 61.25d | 0d | SSH-Construction Manhours [20001.2 h] | 120,000 |  |
| 1.4.1.3.1.210 |  | Geotechnical Soil Investigation | 31.25d | 2011-05-31 | 2011-06-28 | 1.4.1.3.1.200 SS+30d | 61.25d | 0d | SSH-Construction Manhours [25000 h] | 1,707,145 | 0.504285341 |
|  | 2 | **Zone 1** |  | 2011-04-10 | 2011-06-08 |  |  |  |  |  |  |
|  | 2 | **Site Preparation** |  | 2011-04-10 | 2011-06-08 |  |  |  |  |  |  |
| Z1.1010 |  | Site clearing/grubbing/disposal zone1 | 15d | 2011-04-10 | 2011-04-23 | 1.4.1.3.1.010 | 110d | 0d | SSH-Construction Manhours [10500 h]; Grader [120 h]; Dump Truck [120 h] | 85,483 |  |
| Z1.1020 |  | Cutting/backfilling/grading zone1 | 25d | 2011-04-24 | 2011-05-16 | Z1.1010, 1.3.1.6.140 SS | 110d | 0d | SSH-Construction Manhours [14000 h]; Dump Truck [200 h]; Grader [200 h] | 854,826 |  |
| Z1.1030 |  | Install temporary access for Zone 1 | 25d | 2011-05-17 | 2011-06-08 | Z1.1020 | 110d | 0d | SSH-Construction Manhours [14000 h] | 225,000 |  |
|  | 3 | **Zone 3** |  | 2011-07-06 | 2011-09-06 |  |  |  |  |  |  |
|  | 01 | **Site Preparation** |  |  |  |  |  |  |  |  |  |
|  | 02 | **A3-1** |  | 2011-07-06 | 2011-08-15 |  |  |  |  |  |  |
| Z3.1010 |  | Site Clearing/Grubbing/Disposal | 12.5d | 2011-07-06 | 2011-07-17 | 1.4.1.3.1.210 FS+7.5d, M2.04 | 61.25d | 0d | SSH-Construction Manhours [8000 h]; Grader [100 h]; Dump Truck [100 h] | 552,217 |  |
| Z3.1020 |  | Backfill/Compaction of soil upto desired level | 31.25d | 2011-07-18 | 2011-08-15 | Z3.1010, 1.3.1.6.140 SS | 61.25d | 0d | SSH-Construction Manhours [25000 h]; Grader [250 h]; Dump Truck [250 h]; Compactor [250 h] | 2,325,125 |  |

| ID | WBS | Activity | Duration | Start | Finish | Predecessors | Total float | Free float | Resources | Cost |
| --- | --- | --- | --- | --- | --- | --- | --- | --- | --- | --- |
|  | 03 | **A3-2** |  | 2011-07-09 | 2011-08-17 |  |  |  |  |  |
| Z3.2020 |  | Site Clearing/Grubbing/Disposal | 12.5d | 2011-07-09 | 2011-07-19 | 1.4.1.3.3.010 FS+31.25d | 47.5d | 0d | SSH-Construction Manhours [7000 h]; Dump Truck [100 h]; Grader [100 h] | 877,050 |
| Z3.2030 |  | Backfill/Compaction of soil upto desired level | 31.25d | 2011-07-20 | 2011-08-17 | Z3.2020 | 47.5d | 0d | SSH-Construction Manhours [25000 h]; Dump Truck [200 h]; Grader [200 h]; Compactor [250 h] | 3,692,846 |
|  | 04 | **A3-3** |  | 2011-07-09 | 2011-08-23 |  |  |  |  |  |
| Z3.3010 |  | Site Clearing/Grubbing/Disposal | 18.75d | 2011-07-09 | 2011-07-25 | 1.4.1.3.3.010 FS+31.25d | 37.5d | 0d | SSH-Construction Manhours [10500 h]; Grader [150 h]; Dump Truck [150 h] | 974,501 |
| Z3.3020 |  | Backfill/Compaction of soil upto desired level | 31.25d | 2011-07-26 | 2011-08-23 | Z3.3010 | 37.5d | 0d | SSH-Construction Manhours [25000 h]; Grader [250 h]; Dump Truck [250 h] | 4,103,163 |
|  | 05 | **A3-4** |  | 2011-08-07 | 2011-08-30 |  |  |  |  |  |
| Z3.4010 |  | Site Clearing/Grubbing/Disposal | 8.75d | 2011-08-07 | 2011-08-14 | Z3.3020 SS+12.5d | 37.5d | 0d | SSH-Construction Manhours [5600 h]; Grader [70 h]; Dump Truck [70 h] | 552,217 |
| Z3.4020 |  | Backfill/Compaction of soil upto desired level | 17.5d | 2011-08-15 | 2011-08-30 | Z3.4010 | 45d | 7.5d | SSH-Construction Manhours [21000 h]; Excavator [140 h]; Dump Truck [140 h]; Compactor [140 h] | 2,325,125 |
|  | 06 | **A3-5** |  | 2011-08-18 | 2011-09-06 |  |  |  |  |  |
| Z3.5010 |  | Site Clearing/Grubbing/Disposal | 7.5d | 2011-08-18 | 2011-08-24 | Z3.4010 FS+3.75d | 37.5d | 0d | SSH-Construction Manhours [10500 h]; Grader [60 h]; Dump Truck [60 h] | 292,352 |
| Z3.5020 |  | Backfill/Compaction of soil upto desired level | 13.75d | 2011-08-25 | 2011-09-06 | Z3.5010 | 37.5d | 0d | SSH-Construction Manhours [7700 h]; Dump Truck [100 h]; Grader [100 h]; Compactor [110 h] | 1,230,951 |
|  | 4 | **Zone 2** |  | 2011-07-24 | 2011-09-07 |  |  |  |  |  |
|  | 1 | **Site Preparation** |  |  |  |  |  |  |  |  |
|  | 2 | **A2-1** |  | 2011-07-24 | 2011-08-21 |  |  |  |  |  |
| Z2.1010 |  | Site clearing/grubbing/disposal | 7.5d | 2011-07-24 | 2011-07-30 | 1.4.1.3.2.010, M2.07, M2.05 | 62.5d | 0d | SSH-Construction Manhours [10500 h]; Grader [150 h]; Dump Truck [150 h] | 149,594 |
| Z2.1020 |  | Backfill/Compaction of soil upto desired level | 23.75d | 2011-07-31 | 2011-08-21 | Z2.1010 | 62.5d | 0d | SSH-Construction Manhours [14000 h]; Grader [200 h]; Dump Truck [200 h]; Compactor [190 h] | 448,784 |
|  | 3 | **A2-2** |  | 2011-07-24 | 2011-09-07 |  |  |  |  |  |
| Z2.2010 |  | Site clearing/grubbing/disposal | 18.75d | 2011-07-24 | 2011-08-09 | 1.4.1.3.2.010 | 62.5d | 0d | SSH-Construction Manhours [10500 h]; Dump Truck [150 h]; Grader [150 h] | 384,671 |
| Z2.2020 |  | Backfill/Compaction of soil upto desired level | 31.25d | 2011-08-10 | 2011-09-07 | Z2.2010 | 62.5d | 0d | SSH-Construction Manhours [14000 h]; Compactor [250 h] | 1,154,015 |
| Z2.2330 |  | Temoraru access road for zone 2 | 12.5d | 2011-08-28 | 2011-09-07 | Z2.2020 SS+18.75d | 87.5d | 25d | SSH-Construction Manhours [12000 h] | 200,000 |
|  | 5 | **Zone 4** |  | 2011-09-08 | 2011-11-05 |  |  |  |  |  |
|  | 1 | **Site Preparation** |  | 2011-09-08 | 2011-11-05 |  |  |  |  |  |
| Z4.1010 |  | Site clearing/grubbing/disposal zone4 | 25d | 2011-09-08 | 2011-10-01 | 1.4.1.3.4.010 FS+18.75d, M2.06, Z2.2020 | 62.5d | 0d | SSH-Construction Manhours [6000 h]; Dump Truck [200 h]; Grader [200 h] | 341,930 |
| Z4.1020 |  | Supp/backfill/compact gen soil upto des level zone4 | 37.5d | 2011-10-02 | 2011-11-05 | Z4.1010, Z2.2330 | 62.5d | 0d | SSH-Construction Manhours [18000 h]; Dump Truck [250 h]; Grader [250 h]; Compactor [250 h] | 1,025,791 |

| ID | WBS | Activity | Duration | Start | Finish | Predecessors | Total float | Free float | Resources | Cost |
| --- | --- | --- | --- | --- | --- | --- | --- | --- | --- | --- |
|  | 2 | **Sewer Sanitary System** |  | 2011-07-14 | 2012-06-19 |  |  |  |  |  |
|  | 1 | **Zone 1** |  |  |  |  |  |  |  |  |
|  | 1 | **A1** |  |  |  |  |  |  |  |  |
|  | 2 | **Zone 3** |  | 2011-07-14 | 2012-06-19 |  |  |  |  |  |
|  | 1 | **A3-1** |  | 2011-08-16 | 2012-06-06 |  |  |  |  |  |
| Z3.1180 |  | Excavation for sewer trench SMH02RA-SMH08RA+Dewatering | 12.5d | 2011-08-16 | 2011-08-27 | Z3.1020 | 70d | 0d | SSH-Construction Manhours [7000 h]; Excavator [100 h]; Dump Truck [100 h] | 192,667 |
| Z3.1190 |  | Installation of Sewer Manholes 01 - 07 (7) | 31.25d | 2011-08-28 | 2011-09-25 | Z3.1180 | 70d | 0d | SSH-Construction Manhours [25000 h] | 34,994 |
| Z3.1030 |  | Excavation for gravity trench SMH19R3-SMH11R3+Dewatering | 22.5d | 2011-09-07 | 2011-09-27 | Z3.1020, M2.08 | 37.5d | 0d | SSH-Construction Manhours [5400 h]; Excavator [180 h]; Dump Truck [180 h] | 192,677 |
| Z3.1210 |  | Installation of sewer pipe (560LM) | 20d | 2011-09-26 | 2011-10-13 | Z3.1190 | 70d | 0d | SSH-Construction Manhours [16000 h] | 56,382 |
| Z3.1040 |  | Installation of Sewer Manholes SMH19R3-SMH11R3(9) | 31.25d | 2011-09-28 | 2011-10-26 | Z3.1030, 1.3.5.2.1.030 | 37.5d | 0d | SSH-Construction Manhours [37500 h] | 34,994 |
| Z3.1211 |  | Excavation for sewer trench SMH06RA- SMH08RA | 10d | 2011-10-15 | 2011-10-23 | Z3.1210 | 70d | 0d | SSH-Construction Manhours [7000 h] | 192,667 |
| Z3.1212 |  | Install sewer manholes (3) | 31.25d | 2011-10-24 | 2011-11-21 | Z3.1211 | 70d | 0d | SSH-Construction Manhours [10500 h] | 34,994 |
| Z3.1050 |  | Installation of sewer pipe (750LM) | 25d | 2011-10-27 | 2011-11-19 | Z3.1040, 1.3.5.2.2.030 | 37.5d | 0d | SSH-Construction Manhours [30000 h] | 56,383 |
| Z3.1051 |  | Install sewer manhoels SMH11R2-SMH08R4 (03) | 31.25d | 2011-11-20 | 2011-12-18 | Z3.1050 | 37.5d | 0d | SSH-Construction Manhours [12500 h] | 35,144 |
| Z3.1213 |  | Install sewer pipe line (210LM) | 12.5d | 2011-11-22 | 2011-12-03 | Z3.1212 | 70d | 0d | SSH-Construction Manhours [5000 h] | 56,382 |
| Z3.1214 |  | Excavation for sewer trench SMH01RP- SMH07RP | 18.75d | 2011-12-04 | 2011-12-20 | Z3.1213 | 70d | 0d | SSH-Construction Manhours [9000 h] | 192,667 |
| Z3.1052 |  | Install sewer pipe (325LM) | 25d | 2011-12-19 | 2012-01-10 | Z3.1051 | 37.5d | 0d | SSH-Construction Manhours [13000 h] | 56,382 |
| Z3.1215 |  | Install sewer manholes (7) | 31.25d | 2011-12-21 | 2012-01-18 | Z3.1214 | 70d | 0d | SSH-Construction Manhours [22000 h] | 34,994 |
| Z3.1060 |  | Partial Backfilling | 7.5d | 2012-01-11 | 2012-01-17 | Z3.1052 | 37.5d | 0d | SSH-Construction Manhours [4200 h]; Dump Truck [60 h] | 229,787 |
| Z3.1216 |  | Install sewer pipeline (575LM) | 30d | 2012-01-19 | 2012-02-15 | Z3.1215 | 70d | 0d | SSH-Construction Manhours [12000 h] | 56,382 |
| Z3.1220 |  | Partial Backfilling | 7.5d | 2012-02-16 | 2012-02-22 | Z3.1210, Z3.1216 | 70d | 7.5d | SSH-Construction Manhours [4200 h]; Dump Truck [60 h] | 229,787 |
| Z3.1100 |  | Excavation for sewer trench SMH11R3-LS10+Dewatering | 6.25d | 2012-03-25 | 2012-03-29 | Z3.1090 | 37.5d | 0d | SSH-Construction Manhours [3500 h]; Excavator [50 h]; Dump Truck [50 h] | 192,667 |
| Z3.1110 |  | Installation of Sewer Manholes SMH11R3-LS10 (5) | 25d | 2012-03-31 | 2012-04-22 | Z3.1100 | 37.5d | 0d | SSH-Construction Manhours [30000 h] | 34,994 |
| Z3.1120 |  | Installation of Sewer Pipe (225LM) | 15d | 2012-04-23 | 2012-05-06 | Z3.1110 | 37.5d | 0d | SSH-Construction Manhours [18000 h] | 56,382 |
| Z3.1130 |  | Installation of Sewer Manholes SMHRL1-SMH07RP (4) | 21.25d | 2012-05-07 | 2012-05-26 | Z3.1120 | 37.5d | 0d | SSH-Construction Manhours [25500 h] | 34,994 |
| Z3.1140 |  | Installation of Sewer Pipe SMHRL1-SMH07RP (290LM) | 12.5d | 2012-05-27 | 2012-06-06 | Z3.1130 | 37.5d | 0d | SSH-Construction Manhours [10000 h] | 56,382 |

| ID | WBS | Activity | Duration | Start | Finish | Predecessors | Total float | Free float | Resources | Cost |
| --- | --- | --- | --- | --- | --- | --- | --- | --- | --- | --- |
|  | 2 | **A3-2** |  | 2011-07-14 | 2012-03-06 |  |  |  |  |  |
| Z3.2075 |  | Installation of Manholes SMH01R2-SMH28RA(5) | 25d | 2011-07-14 | 2011-08-06 | 1.4.1.3.3.010 FS+37.5d | 62.5d | 0d | SSH-Construction Manhours [14000 h] | 61,277 |
| Z3.2080 |  | Installation of sewer pipe SMH01R2-SMH28RA (300LM) | 27.5d | 2011-08-07 | 2011-08-31 | Z3.2075 | 62.5d | 0d | SSH-Construction Manhours [39600 h] | 98,670 |
| Z3.2040 |  | Excavation for sanitary trench SMH06R3 -SMH05R4 | 25d | 2011-08-18 | 2011-09-10 | Z3.2030, 1.2.6.200 | 47.5d | 0d | SSH-Construction Manhours [14000 h]; Excavator [200 h]; Dump Truck [200 h] | 107,037 |
| Z3.2090 |  | Installation of Manholes SMHRL16 -SMH28RA (7) | 31.25d | 2011-09-01 | 2011-09-29 | Z3.2080 | 62.5d | 0d | SSH-Construction Manhours [25000 h] | 61,277 |
| Z3.2045 |  | Installation of Manholes SMH06R3 -SMH05R4 (5) | 25d | 2011-09-11 | 2011-10-03 | Z3.2040 | 47.5d | 0d | SSH-Construction Manhours [20000 h] | 61,277 |
| Z3.2110 |  | Excavation for sanitary trench SMH01R3-LS11 | 18.75d | 2011-10-01 | 2011-10-17 | Z3.2090 | 62.5d | 0d | SSH-Construction Manhours [10500 h]; Excavator [150 h]; Dump Truck [150 h] | 321,113 |
| Z3.2050 |  | Installation of sewer pipe SMH06R3 -SMH05R4 (400LM) | 31.25d | 2011-10-04 | 2011-11-01 | Z3.2045 | 47.5d | 0d | SSH-Construction Manhours [37500 h] | 98,670 |
| Z3.2120 |  | Installation of sewer pipe SMH01R3-LS11(327LM) | 31.25d | 2011-10-18 | 2011-11-15 | Z3.2110 | 62.5d | 0d | SSH-Construction Manhours [37500 h] | 98,670 |
| Z3.2051 |  | Excavation for sanitary trench SMH05R3-SMH01R | 15d | 2011-11-02 | 2011-11-15 | Z3.2050 | 136.25d | 0d | SSH-Construction Manhours [8000 h] | 107,037 |
| Z3.2055 |  | Installation of Manholes SMH05R3 -SMH01R3 (5) | 25d | 2011-11-16 | 2011-12-08 | Z3.2050, Z3.2051 | 136.25d | 0d | SSH-Construction Manhours [20000 h] | 61,277 |
| Z3.2130 |  | Excavation of sanitary trench SMHRL16 -LS11 | 12.5d | 2011-11-16 | 2011-11-27 | Z3.2120 | 62.5d | 0d | SSH-Construction Manhours [7000 h]; Excavator [100 h]; Dump Truck [100 h] | 321,113 |
| Z3.2140 |  | Installation of Manholes SMHRL16 -LS11 (7) | 26.25d | 2011-11-28 | 2011-12-21 | Z3.2130 | 62.5d | 0d | SSH-Construction Manhours [21000 h] | 61,277 |
| Z3.2060 |  | Installation of sewer pipe SMH05R3 -SMH01R3 (360LM) | 27.5d | 2011-12-10 | 2012-01-03 | Z3.2055 | 136.25d | 0d | SSH-Construction Manhours [33000 h] | 98,670 |
| Z3.2150 |  | Installation of sewer pipe SMHRL16 -LS11 (730LM) | 22.5d | 2011-12-22 | 2012-01-11 | Z3.2140 | 62.5d | 0d | SSH-Construction Manhours [27000 h] | 98,670 |
| Z3.2065 |  | Installation of Manholes SMH01R3 -SMH28RA (5) | 25d | 2012-01-04 | 2012-01-26 | Z3.2060 | 136.25d | 0d | SSH-Construction Manhours [20000 h] | 61,277 |
| Z3.2066 |  | Excavation of sewer trench SMH01R3-SMH28RA | 15d | 2012-01-28 | 2012-02-09 | Z3.2065 | 136.25d | 0d | SSH-Construction Manhours [10000 h] | 107,038 |
| Z3.2070 |  | Installation of sewer pipe SMH01R3 -SMH28RA (380LM) | 27.5d | 2012-02-11 | 2012-03-06 | Z3.2066 | 136.25d | 98.75d | SSH-Construction Manhours [33000 h] | 98,670 |
|  | 3 | **A3-3** |  | 2011-08-24 | 2012-06-19 |  |  |  |  |  |
| Z3.3110 |  | Excavation for sewer line SMH13RA-SMH09RA | 18.75d | 2011-08-24 | 2011-09-10 | Z3.3020 | 62.5d | 0d | SSH-Construction Manhours [10500 h]; Excavator [150 h]; Dump Truck [150 h] | 321,113 |
| Z3.3120 |  | Instalaltion of sewer Manholes SMH13RA-SMH09RA (5) | 31.25d | 2011-09-11 | 2011-10-09 | Z3.3110 | 62.5d | 0d | SSH-Construction Manhours [25000 h] | 61,277 |
| Z3.3130 |  | Instalaltion of sewer line SMH13RA-SMH09RA (285LM) | 18.75d | 2011-10-10 | 2011-10-26 | Z3.3120 | 62.5d | 0d | SSH-Construction Manhours [22500 h] | 98,670 |
| Z3.3140 |  | Excavation for sewer line SMH09RA-SMH11R2 | 12.5d | 2011-10-27 | 2011-11-07 | Z3.3130 | 62.5d | 0d | SSH-Construction Manhours [7000 h]; Excavator [100 h]; Dump Truck [100 h] | 321,113 |
| Z3.3150 |  | Installation of sewer manhole SMH09RA-SMH11R2 (3) | 18.75d | 2011-11-08 | 2011-11-24 | Z3.3140 | 62.5d | 0d | SSH-Construction Manhours [15000 h] | 61,277 |
| Z3.3160 |  | Installaiton of sewer line SMH09RA-SMH11R2 (270LM) | 16.25d | 2011-11-26 | 2011-12-10 | Z3.3150 | 62.5d | 0d | SSH-Construction Manhours [19500 h] | 98,670 |
| Z3.3170 |  | Excavation for sewer line SMH13RA - SMH01R2 | 25d | 2011-12-11 | 2012-01-02 | Z3.3160 | 62.5d | 0d | SSH-Construction Manhours [14000 h]; Excavator [200 h]; Dump Truck [200 h] | 321,113 |
| Z3.3180 |  | Installaiton of manholes SMH13RA - SMH01R2 (7) | 31.25d | 2012-01-03 | 2012-01-31 | Z3.3170 | 62.5d | 0d | SSH-Construction Manhours [37500 h] | 61,277 |
| Z3.3190 |  | Installation of sewer line SMH13RA - SMH01R2 (598LM) | 31.25d | 2012-02-01 | 2012-02-29 | Z3.3180 | 62.5d | 0d | SSH-Construction Manhours [50000 h] | 98,670 |
| Z3.3200 |  | Excavation for sewer line SM10R2 - SM02R2 | 25d | 2012-03-01 | 2012-03-24 | Z3.3190, Z3.1220 | 62.5d | 0d | SSH-Construction Manhours [14000 h]; Excavator [200 h]; Dump Truck [200 h] | 321,113 |
| Z3.3210 |  | Installation of sewer manholes SM10R2 - SM02R2 (9) | 31.25d | 2012-03-25 | 2012-04-22 | Z3.3200 | 62.5d | 0d | SSH-Construction Manhours [17500 h] | 61,277 |
| Z3.3220 |  | Installation of sewer line SM10R2 - SM02R2 (780)A | 31.25d | 2012-04-23 | 2012-05-21 | Z3.3210 | 62.5d | 0d | SSH-Construction Manhours [17500 h] | 98,670 |
| Z3.3230 |  | Installation of sewer line SM10R2 - SM02R2 (780)B | 31.25d | 2012-05-22 | 2012-06-19 | Z3.3220 | 62.5d | 0d | SSH-Construction Manhours [17500 h] | 98,670 |

| ID | WBS | Activity | Duration | Start | Finish | Predecessors | Total float | Free float | Resources | Cost |
| --- | --- | --- | --- | --- | --- | --- | --- | --- | --- | --- |
|  | 4 | **A3-4** |  |  |  |  |  |  |  |  |
|  | 5 | **A3-5** |  | 2012-02-01 | 2012-04-10 |  |  |  |  |  |
| Z3.5030 |  | Excvation for sewer line SMH10R3-SMH01R4 | 18.75d | 2012-02-01 | 2012-02-18 | Z3.5020, Z3.4030 | 97.5d | 0d | SSH-Construction Manhours [6000 h]; Excavator [150 h]; Dump Truck [150 h] | 321,113 |
| Z3.5040 |  | Installation of sewer manholes SMH10R3-SMH01R4(5) | 25d | 2012-02-19 | 2012-03-12 | Z3.5030 | 97.5d | 0d | SSH-Construction Manhours [20000 h] | 61,277 |
| Z3.5050 |  | Installation of sewer line SMH10R3-SMH01R4 (350LM) | 31.25d | 2012-03-13 | 2012-04-10 | Z3.5040 | 97.5d | 0d | SSH-Construction Manhours [37500 h] | 98,674 |
|  | 3 | **Zone 2** |  | 2011-07-24 | 2012-04-22 |  |  |  |  |  |
|  | 1 | **A2-1** |  | 2011-08-22 | 2011-10-31 |  |  |  |  |  |
| Z2.1030 |  | Excavation for sewer line SMH01RC-SMH04R7 | 18.75d | 2011-08-22 | 2011-09-07 | Z2.1020 | 62.5d | 0d | SSH-Construction Manhours [10500 h]; Excavator [150 h]; Dump Truck [150 h] | 156,000 |
| Z2.1040 |  | Install sewer manholes SMH01RC-SMH04R7 (5) | 26.25d | 2011-09-08 | 2011-10-02 | Z2.1030 | 62.5d | 0d | SSH-Construction Manhours [21000 h] | 76,974 |
| Z2.1050 |  | Install sewer line SMH01RC-SMH04R7 (350LM) | 31.25d | 2011-10-03 | 2011-10-31 | Z2.1040 | 62.5d | 0d | SSH-Construction Manhours [37500 h] | 77,284 |
|  | 2 | **A2-2** |  | 2011-07-24 | 2012-04-22 |  |  |  |  |  |
| Z2.2120 |  | Excavation for sewer trench SMH01R7-SMH04R7 | 18.75d | 2011-07-24 | 2011-08-09 | 1.4.1.3.2.010 | 86.25d | 0d | SSH-Construction Manhours [10500 h]; Dump Truck [150 h]; Excavator [150 h] | 156,000 |
| Z2.2130 |  | Install sewer manholes SMH01R7-SMH04R7 (5) | 25d | 2011-08-10 | 2011-09-01 | Z2.2120 | 86.25d | 0d | SSH-Construction Manhours [20000 h] | 76,974 |
| Z2.2140 |  | Install sewer line SMH01R7-SMH04R7 (330LM) | 18.75d | 2011-09-03 | 2011-09-19 | Z2.2130 | 86.25d | 0d | SSH-Construction Manhours [22500 h] | 77,276 |
| Z2.2030 |  | Excavation for sewer trench SMH05R7 - SMH18RC | 18.75d | 2011-09-08 | 2011-09-25 | Z2.2020 | 117.5d | 0d | SSH-Construction Manhours [10500 h]; Excavator [150 h]; Dump Truck [150 h] | 156,000 |
| Z2.2150 |  | Excavation for sewer trench SMH04R7-SMH12RC | 25d | 2011-09-20 | 2011-10-12 | Z2.2140 | 86.25d | 0d | SSH-Construction Manhours [14000 h]; Dump Truck [200 h]; Excavator [200 h] | 156,000 |
| Z2.2040 |  | Install sewer manholes SMH05R7 - SMH18RC (6) | 31.25d | 2011-09-26 | 2011-10-24 | Z2.2030 | 117.5d | 0d | SSH-Construction Manhours [25000 h] | 76,974 |
| Z2.2160 |  | Installation of manhoels SMH04R7-SMH12RC (11) | 31.25d | 2011-10-13 | 2011-11-10 | Z2.2150 | 86.25d | 0d | SSH-Construction Manhours [25000 h] | 76,974 |
| Z2.2050 |  | Install sewer line SMH05R7 - SMH18RC (406LM) | 25d | 2011-10-25 | 2011-11-16 | Z2.2040 | 117.5d | 0d | SSH-Construction Manhours [30000 h] | 77,276 |
| Z2.2170 |  | Installation of sewer line SMH04R7-SMH12RC (652LM)A | 18.75d | 2011-11-12 | 2011-11-28 | Z2.2160 | 86.25d | 0d | SSH-Construction Manhours [22500 h] | 77,276 |
| Z2.2060 |  | Excavation for sewer line SMH13R7-SMH17RC | 18.75d | 2011-11-17 | 2011-12-04 | Z2.2050, M2.09 | 117.5d | 0d | SSH-Construction Manhours [10500 h]; Dump Truck [150 h]; Excavator [150 h] | 156,000 |
| Z2.2180 |  | Installation of sewer line SMH04R7-SMH12RC (652LM)B | 18.75d | 2011-11-29 | 2011-12-15 | Z2.2170 | 86.25d | 0d | SSH-Construction Manhours [22500 h] | 77,276 |
| Z2.2070 |  | Install sewer line manhole SMH13R7-SMH17RC (5) | 25d | 2011-12-05 | 2011-12-27 | Z2.2060 | 117.5d | 0d | SSH-Construction Manhours [20000 h] | 76,974 |
| Z2.2190 |  | Excavation for sewer line SMH02AR7-interface point-A | 18.75d | 2011-12-17 | 2012-01-02 | Z2.2180 | 86.25d | 0d | SSH-Construction Manhours [10500 h]; Dump Truck [150 h]; Excavator [150 h] | 156,000 |
| Z2.2080 |  | Install sewer line SMH13R7-SMH17RC (294LM) | 18.75d | 2011-12-28 | 2012-01-14 | Z2.2070 | 117.5d | 0d | SSH-Construction Manhours [22500 h] | 77,276 |
| Z2.2200 |  | Instal F.sewer line SMH02AR7-interface point (29040LM)A | 25d | 2012-01-03 | 2012-01-25 | Z2.2190 | 86.25d | 0d | SSH-Construction Manhours [30000 h] | 77,276 |
| Z2.2090 |  | Excavation for sewer line SMH17RC-SMH12RC | 18.75d | 2012-01-15 | 2012-01-31 | Z2.2080 | 117.5d | 0d | SSH-Construction Manhours [10500 h]; Dump Truck [150 h]; Excavator [150 h] | 156,000 |
| Z2.2202 |  | Excavation for sewer line SMH02AR7-interface point-B | 18.75d | 2012-01-26 | 2012-02-12 | Z2.2200 | 86.25d | 0d | SSH-Construction Manhours [6000 h]; Dump Truck [150 h]; Excavator [150 h] | 156,000 |
| Z2.2100 |  | Install sewer manholes SMH17RC-SMH12RC (7) | 31.25d | 2012-02-01 | 2012-02-29 | Z2.2090 | 117.5d | 0d | SSH-Construction Manhours [17500 h] | 76,974 |
| Z2.2210 |  | Instal F.sewer line SMH02AR7-interface point (2940LM)B | 25d | 2012-02-13 | 2012-03-06 | Z2.2202 | 86.25d | 0d | SSH-Construction Manhours [14000 h] | 77,276 |
| Z2.2110 |  | Install sewer line SMH17RC-SMH12RC (410LM) | 25d | 2012-03-01 | 2012-03-24 | Z2.2100 | 117.5d | 80d | SSH-Construction Manhours [30000 h] | 77,276 |
| Z2.2212 |  | Excavation for sewer line SMH02AR7-interface point-C | 18.75d | 2012-03-07 | 2012-03-24 | Z2.2210 | 86.25d | 0d | SSH-Construction Manhours [6000 h]; Dump Truck [150 h]; Excavator [150 h] | 156,000 |
| Z2.2220 |  | Instal F.sewer line SMH02AR7-interface point (2940LM)C | 25d | 2012-03-25 | 2012-04-16 | Z2.2212 | 86.25d | 0d | SSH-Construction Manhours [30000 h] | 77,276 |
| Z2.2340 |  | Backfilling | 31.25d | 2012-03-25 | 2012-04-22 | Z2.2220 SS | 86.25d | 48.75d | SSH-Construction Manhours [17500 h] | 230,922 |

| ID | WBS | Activity | Duration | Start | Finish | Predecessors | Total float | Free float | Resources | Cost |
| --- | --- | --- | --- | --- | --- | --- | --- | --- | --- | --- |
|  | 4 | **Zone 4** |  | 2011-11-06 | 2012-06-07 |  |  |  |  |  |
|  | 1 | **A4** |  | 2011-11-06 | 2012-06-07 |  |  |  |  |  |
| Z4.1030 |  | Excavation for sewer line SMH18R2-SMH29R3+Dewatering | 25d | 2011-11-06 | 2011-11-28 | Z4.1020 | 62.5d | 0d | SSH-Construction Manhours [14000 h]; Excavator [200 h]; Dump Truck [200 h] | 364,267 |
| Z4.1040 |  | Install sewer manholes SMH18R2-SMH29R3 (7) | 31.25d | 2011-11-29 | 2011-12-27 | Z4.1030 | 62.5d | 0d | SSH-Construction Manhours [25000 h] | 141,162 |
| Z4.1050 |  | Install sewer line SMH18R2-SMH29R3 (405LM) | 25d | 2011-12-28 | 2012-01-19 | Z4.1040 | 62.5d | 0d | SSH-Construction Manhours [30000 h] | 161,162 |
| Z4.1060 |  | Excavation for sewer line SMH20R3-SMH29R3 | 31.25d | 2012-01-21 | 2012-02-18 | Z4.1050 | 62.5d | 0d | SSH-Construction Manhours [10000 h] | 364,267 |
| Z4.1070 |  | Install sewer manholes SMH20R3-SMH29R3 (7) | 31.25d | 2012-02-19 | 2012-03-18 | Z4.1060, Z1.1060 | 62.5d | 0d | SSH-Construction Manhours [20000 h] | 141,162 |
| Z4.1080 |  | Install sewr line SMH20R3-SMH29R3 (630LM) | 31.25d | 2012-03-19 | 2012-04-16 | Z4.1070 | 62.5d | 0d | SSH-Construction Manhours [37500 h] | 161,162 |
| Z4.1090 |  | Excvation for sewer line SMH20R3- SD CHAMBER | 25d | 2012-04-17 | 2012-05-09 | Z4.1080 | 62.5d | 0d | SSH-Construction Manhours [10000 h]; Excavator [200 h]; Dump Truck [200 h] | 364,267 |
| Z4.1100 |  | Install sewer line SMH20R3- SD CHAMBER | 31.25d | 2012-05-10 | 2012-06-07 | Z4.1090 | 62.5d | 0d | SSH-Construction Manhours [17500 h] | 161,162 |
| Z4.1180 |  | Backfilling | 31.25d | 2012-05-10 | 2012-06-07 | Z4.1100 SS | 62.5d | 0d | SSH-Construction Manhours [12500 h] | 141,159 |
|  | 3 | **PW / FW / CTMU(Cooling Tower Make Up) / Irrigation / Sea water Line** |  | 2011-08-21 | 2012-10-20 |  |  |  |  |  |
|  | 1 | **Zone 1** |  | 2011-08-21 | 2011-10-17 |  |  |  |  |  |
|  | 1 | **A1** |  | 2011-08-21 | 2011-10-17 |  |  |  |  |  |
| Z1.1040 |  | Excavation for water line & Valve boxes(2) | 25d | 2011-08-21 | 2011-09-12 | Z1.1030 FS+37.5d, 1.4.1.2.1.020 SS | 195d | 0d | SSH-Construction Manhours [14000 h]; Excavator [200 h]; Dump Truck [200 h] | 4,800 |
| Z1.1050 |  | Construction of vale boxes(2) | 31.25d | 2011-09-13 | 2011-10-11 | Z1.1040 | 195d | 0d | SSH-Construction Manhours [37500 h] | 26,432 |
| Z1.1060 |  | Install PW/FW/CTMU line +Irrigation line (375LM) | 25d | 2011-09-25 | 2011-10-17 | Z1.1050 SS+12.5d | 195d | 132.5d | SSH-Construction Manhours [60000 h] | 130,000 |
|  | 2 | **Zone 3** |  | 2011-09-29 | 2012-10-20 |  |  |  |  |  |
|  | 1 | **A3-1** |  | 2011-09-29 | 2012-10-20 |  |  |  |  |  |
| Z3.1230 |  | Construction of Valve boxes for water line (7) | 31.25d | 2011-09-29 | 2011-10-27 | 1.4.1.2.2.040 | 106.25d | 0d | SSH-Construction Manhours [25000 h] | 92,512 |
| Z3.1240 |  | Installation of PW/FW/CTMU line-A(825) + Irrigation line | 31.25d | 2011-10-29 | 2011-11-26 | Z3.1230 | 106.25d | 0d | SSH-Construction Manhours [75000 h] | 75,000 |
| Z3.1250 |  | Installation of PW/FW/CTMU line-B(825) + Irrigation line | 31.25d | 2011-11-27 | 2011-12-25 | Z3.1240 | 106.25d | 0d | SSH-Construction Manhours [75000 h] | 75,000 |
| Z3.1260 |  | Installation of PW/FW/CTMU line-C(825) + Irrigation line | 31.25d | 2011-12-26 | 2012-01-23 | Z3.1250 | 106.25d | 0d | SSH-Construction Manhours [75000 h] | 75,000 |
| Z3.1070 |  | Construction of Valve boxes for water line (4) | 21.25d | 2012-01-18 | 2012-02-06 | Z3.1060 | 37.5d | 0d | SSH-Construction Manhours [17000 h]; Excavator [170 h]; Dump Truck [170 h] | 52,864 |
| Z3.1270 |  | Installation of PW/FW/CTMU line-D(825) + Irrigation line | 31.25d | 2012-01-24 | 2012-02-21 | Z3.1260 | 106.25d | 0d | SSH-Construction Manhours [75000 h] | 75,000 |
| Z3.1080 |  | Installation of PW/FW/CTMU line-A(375LM) + irrigation line | 25d | 2012-02-07 | 2012-02-29 | Z3.1070, 1.3.5.1.2.030, 1.3.5.3.1.030 | 37.5d | 0d | SSH-Construction Manhours [60000 h] | 75,000 |
| Z3.1280 |  | Instalaltion of seawater line (825LM) A | 31.25d | 2012-02-22 | 2012-03-21 | Z3.1270 | 106.25d | 0d | SSH-Construction Manhours [12500 h] | 130,421 |
| Z3.1090 |  | Installation of PW/FW/CTMU line-B(375LM) + irrigation line | 25d | 2012-03-01 | 2012-03-24 | Z3.1080 | 37.5d | 0d | SSH-Construction Manhours [60000 h] | 75,000 |
| Z3.1290 |  | Instalaltion of seawater line (825LM) B | 31.25d | 2012-03-22 | 2012-04-19 | Z3.1280 | 106.25d | 0d | SSH-Construction Manhours [12500 h] | 130,421 |
| Z3.1300 |  | Instalaltion of seawater line (825LM) C | 31.25d | 2012-04-21 | 2012-05-19 | Z3.1290 | 106.25d | 0d | SSH-Construction Manhours [12500 h] | 130,421 |
| Z3.1340 |  | Install valves | 31.25d | 2012-05-06 | 2012-06-04 | Z3.1230 FS+37.5d, 1.3.5.1.3.030, 1.3.5.3.2.030 | 120.5d | 57.5d | SSH-Construction Manhours [25000 h] | 176,971 |
| Z3.1310 |  | Instalaltion of seawater line (825LM) D | 31.25d | 2012-05-20 | 2012-06-17 | Z3.1300 | 106.25d | 43.25d | SSH-Construction Manhours [12500 h] | 130,421 |
| Z3.1320 |  | Install fire hydrants | 56.25d | 2012-07-28 | 2012-09-18 | Z3.1310, Z3.1340, 1.3.5.1.3.060 | 63d | 0d | SSH-Construction Manhours [27000 h] | 200,000 |
| Z3.1330 |  | Install irrigation system & accs | 40d | 2012-09-12 | 2012-10-20 | Z3.1320 SS+50d | 63d | 0.5d | SSH-Construction Manhours [16000 h] | 175,000 |

| ID | WBS | Activity | Duration | Start | Finish | Predecessors | Total float | Free float | Resources | Cost |
| --- | --- | --- | --- | --- | --- | --- | --- | --- | --- | --- |
|  | 2 | **A3-2** |  | 2011-10-04 | 2012-10-20 |  |  |  |  |  |
| Z3.2160 |  | Construction for valve boxes (11) | 27.5d | 2011-10-04 | 2011-10-29 | Z3.2050 SS | 47.5d | 0d | SSH-Construction Manhours [15400 h]; Excavator [220 h]; Dump Truck [220 h] | 145,376 |
| Z3.2170 |  | Install PW/FW/CTMU line + Irrigation line A(1200LM) | 31.25d | 2011-10-30 | 2011-11-27 | Z3.2160 | 47.5d | 0d | SSH-Construction Manhours [75000 h] | 75,000 |
| Z3.2180 |  | Install PW/FW/CTMU line + Irrigation line B(1200LM) | 31.25d | 2011-11-28 | 2011-12-26 | Z3.2170 | 47.5d | 0d | SSH-Construction Manhours [75000 h] | 75,000 |
| Z3.2190 |  | Install PW/FW/CTMU line + Irrigation line C(1200LM) | 31.25d | 2011-12-27 | 2012-01-24 | Z3.2180 | 80d | 0d | SSH-Construction Manhours [75000 h] | 75,000 |
| Z3.2210 |  | Install Seawater line (1650LM) A | 31.25d | 2012-01-12 | 2012-02-09 | Z3.2150 | 62.5d | 0d | SSH-Construction Manhours [25000 h] | 130,421 |
| Z3.2200 |  | Install PW/FW/CTMU line + Irrigation line D(1200LM) | 31.25d | 2012-01-25 | 2012-02-22 | Z3.2190 | 80d | 17.5d | SSH-Construction Manhours [75000 h] | 75,000 |
| Z3.2220 |  | Install Seawater line (1650LM) B | 31.25d | 2012-02-11 | 2012-03-10 | Z3.2210 | 62.5d | 0d | SSH-Construction Manhours [25000 h] | 130,421 |
| Z3.2230 |  | Install Seawater line (1650LM) C | 31.25d | 2012-03-11 | 2012-04-08 | Z3.2220, Z3.2200 | 62.5d | 0d | SSH-Construction Manhours [12500 h] | 130,421 |
| Z3.2310 |  | Install valves | 31.25d | 2012-03-18 | 2012-04-15 | Z3.2160 FS+150d | 211.25d | 148.75d | SSH-Construction Manhours [25000 h] | 176,971 |
| Z3.2240 |  | Install Seawater line (1650LM) D | 31.25d | 2012-04-09 | 2012-05-07 | Z3.2230 | 62.5d | 0d | SSH-Construction Manhours [12500 h] | 130,421 |
| Z3.2250 |  | Install Seawater line (1650LM) E | 31.25d | 2012-05-08 | 2012-06-05 | Z3.2240 | 62.5d | 0d | SSH-Construction Manhours [12500 h] | 130,421 |
| Z3.2260 |  | Install seawater line (600LM)A | 31.25d | 2012-06-06 | 2012-07-04 | Z3.2250 | 62.5d | 0d | SSH-Construction Manhours [12500 h] | 130,421 |
| Z3.2270 |  | Install seawater line (600LM)B | 31.25d | 2012-07-05 | 2012-08-02 | Z3.2260 | 62.5d | 0d | SSH-Construction Manhours [12500 h] | 130,421 |
| Z3.2280 |  | Install seawater line (600LM)C | 31.25d | 2012-08-04 | 2012-09-01 | Z3.2270 | 62.5d | 0d | SSH-Construction Manhours [12500 h] | 130,421 |
| Z3.2290 |  | Install fire hydrants | 52.5d | 2012-09-02 | 2012-10-20 | Z3.2280, Z3.2310, 1.3.5.1.3.060 | 62.5d | 0d | SSH-Construction Manhours [21000 h] | 200,000 |
| Z3.2300 |  | Install irrigation system & accs | 52.5d | 2012-09-02 | 2012-10-20 | Z3.2290 SS | 62.5d | 0d | SSH-Construction Manhours [21000 h] | 175,000 |
|  | 3 | **A3-3** |  | 2012-06-20 | 2012-10-20 |  |  |  |  |  |
| Z3.3235 |  | Construction of valve boxes (12) A | 31.25d | 2012-06-20 | 2012-07-18 | Z3.3230 | 62.5d | 0d | SSH-Construction Manhours [15000 h]; Excavator [250 h]; Dump Truck [250 h] | 79,296 |
| Z3.3236 |  | Construction of valve boxes (12) B | 31.25d | 2012-07-19 | 2012-08-16 | Z3.3235 | 75d | 0d | SSH-Construction Manhours [15000 h]; Excavator [250 h]; Dump Truck [250 h] | 79,296 |
| Z3.3240 |  | Installation of PW/FW/CTMU line + Irrigation line A | 25d | 2012-07-19 | 2012-08-11 | Z3.3235 | 62.5d | 0d | SSH-Construction Manhours [20000 h] | 75,000 |
| Z3.3250 |  | Installation of PW/FW/CTMU line + Irrigation line B | 25d | 2012-08-12 | 2012-09-03 | Z3.3240 | 62.5d | 0d | SSH-Construction Manhours [30000 h] | 75,000 |
| Z3.3280 |  | Install valves | 31.25d | 2012-08-18 | 2012-09-15 | Z3.3236 | 75d | 12.5d | SSH-Construction Manhours [25000 h] | 176,971 |
| Z3.3260 |  | Installation of PW/FW/CTMU line + Irrigation line C | 25d | 2012-09-04 | 2012-09-26 | Z3.3250 | 62.5d | 0d | SSH-Construction Manhours [30000 h] | 75,000 |
| Z3.3270 |  | Install fire hydrants | 25d | 2012-09-27 | 2012-10-20 | Z3.3260, Z3.3280, 1.3.5.1.3.060 | 62.5d | 0d | SSH-Construction Manhours [12000 h] | 200,000 |

| ID | WBS | Activity | Duration | Start | Finish | Predecessors | Total float | Free float | Resources | Cost |
| --- | --- | --- | --- | --- | --- | --- | --- | --- | --- | --- |
|  | 4 | **A3-4** |  | 2012-01-03 | 2012-04-28 |  |  |  |  |  |
| Z3.4030 |  | Install seawater line (1050LM)A | 31.25d | 2012-01-03 | 2012-01-31 | Z3.4020, Z3.3170 | 97.5d | 0d | SSH-Construction Manhours [25000 h] | 130,421 |
| Z3.4040 |  | Install seawater line (1050LM)B | 31.25d | 2012-02-01 | 2012-02-29 | Z3.4030 | 110d | 0d | SSH-Construction Manhours [25000 h] | 130,421 |
| Z3.4050 |  | Install seawater line (1050LM)C | 31.25d | 2012-03-01 | 2012-03-29 | Z3.4040 | 110d | 0d | SSH-Construction Manhours [25000 h] | 130,421 |
| Z3.4060 |  | Install seawater line (1050LM)D | 31.25d | 2012-03-31 | 2012-04-28 | Z3.4050 | 110d | 12.5d | SSH-Construction Manhours [25000 h] | 130,421 |
|  | 5 | **A3-5** |  | 2012-04-11 | 2012-07-07 |  |  |  |  |  |
| Z3.5060 |  | Install seawater line (600LM)A | 31.25d | 2012-04-11 | 2012-05-09 | Z3.5050 | 97.5d | 0d | SSH-Construction Manhours [45000 h] | 130,421 |
| Z3.5070 |  | Install seawater line (600LM)B | 31.25d | 2012-05-10 | 2012-06-07 | Z3.5060, Z3.4060 | 97.5d | 0d | SSH-Construction Manhours [45000 h] | 130,421 |
| Z3.5080 |  | Install seawater line (600LM)C | 31.25d | 2012-06-09 | 2012-07-07 | Z3.5070 | 97.5d | 48.5d | SSH-Construction Manhours [45000 h] | 130,421 |
|  | 3 | **Zone 2** |  | 2011-10-02 | 2012-09-18 |  |  |  |  |  |
|  | 1 | **A2-1** |  | 2011-11-01 | 2012-09-18 |  |  |  |  |  |
| Z2.1060 |  | Excavation for valve boxes & water line trench | 25d | 2011-11-01 | 2011-11-23 | Z2.1050 | 62.5d | 0d | SSH-Construction Manhours [14000 h]; Excavator [200 h]; Dump Truck [200 h] | 22,894 |
| Z2.1070 |  | Construction of vale boxes for water line (5) | 31.25d | 2011-11-24 | 2011-12-22 | Z2.1060 | 62.5d | 0d | SSH-Construction Manhours [25000 h] | 66,080 |
| Z2.1080 |  | Install PW/FW/CTMU line+irrigation line (1200LM)A+Seawater | 31.25d | 2011-12-24 | 2012-01-21 | Z2.1070 | 62.5d | 0d | SSH-Construction Manhours [75000 h] | 244,000 |
| Z2.1120 |  | Install valves | 31.25d | 2011-12-24 | 2012-01-21 | Z2.1070 | 93.75d | 31.25d | SSH-Construction Manhours [25000 h] | 50,000 |
| Z2.1090 |  | Install PW/FW/CTMU line+irrigation line (1200LM)B+Seawater | 31.25d | 2012-01-22 | 2012-02-19 | Z2.1080 | 62.5d | 0d | SSH-Construction Manhours [37500 h] | 244,000 |
| Z2.1100 |  | Install PW/FW/CTMU line+irrigation line (1200LM)C+Seawater | 31.25d | 2012-02-20 | 2012-03-19 | Z2.1090, Z2.1120 | 62.5d | 0d | SSH-Construction Manhours [37500 h] | 244,000 |
| Z2.1110 |  | Install fire hydrants | 56.25d | 2012-07-28 | 2012-09-18 | Z2.1100, 1.3.5.1.3.060 | 96.75d | 34.25d | SSH-Construction Manhours [27000 h] | 75,000 |
|  | 2 | **A2-2** |  | 2011-10-02 | 2012-09-18 |  |  |  |  |  |
| Z2.2230 |  | Excavation for water line trench & valve boxesA | 12.5d | 2011-10-02 | 2011-10-12 | 1.4.1.3.2.010 FS+75d | 128.75d | 0d | SSH-Construction Manhours [7000 h]; Excavator [100 h]; Dump Truck [100 h] | 22,894 |
| Z2.2240 |  | Construction of valve boxesA (2) | 31.25d | 2011-10-13 | 2011-11-10 | Z2.2230 | 128.75d | 0d | SSH-Construction Manhours [25000 h] | 26,432 |
| Z2.2250 |  | Install PW/FW/CTMU line +irrigation line (225LM)A | 15d | 2011-11-12 | 2011-11-24 | Z2.2240 | 128.75d | 0d | SSH-Construction Manhours [36000 h] | 57,800 |
| Z2.2252 |  | Excavation for water line trench & valve boxesB | 15d | 2011-11-26 | 2011-12-08 | Z2.2250 | 128.75d | 0d | SSH-Construction Manhours [8400 h]; Dump Truck [120 h]; Excavator [120 h] | 22,894 |
| Z2.2254 |  | Construction of valve boxesB (2) | 31.25d | 2011-12-10 | 2012-01-07 | Z2.2252 | 128.75d | 0d | SSH-Construction Manhours [25000 h] | 26,432 |
| Z2.2260 |  | Install PW/FW/CTMU line +irrigation line (450LM)B | 22.5d | 2012-01-08 | 2012-01-28 | Z2.2254 | 128.75d | 0d | SSH-Construction Manhours [54000 h] | 57,800 |
| Z2.2262 |  | Excavation for water line trench & valve boxesC | 18.75d | 2012-01-29 | 2012-02-14 | Z2.2260 | 128.75d | 0d | SSH-Construction Manhours [6000 h]; Excavator [150 h]; Dump Truck [150 h] | 22,894 |
| Z2.2264 |  | Construction of valve boxesC (2) | 31.25d | 2012-02-15 | 2012-03-14 | Z2.2262 | 128.75d | 0d | SSH-Construction Manhours [25000 h] | 26,432 |
| Z2.2270 |  | Install PW/FW/CTMU line +irrigation line (825LM)C | 31.25d | 2012-03-15 | 2012-04-12 | Z2.2264 | 128.75d | 0d | SSH-Construction Manhours [75000 h] | 57,800 |
| Z2.2320 |  | Install valves | 31.25d | 2012-03-15 | 2012-04-12 | Z2.2264 | 210d | 113.25d | SSH-Construction Manhours [25000 h] | 175,000 |
| Z2.2280 |  | Excavation for irrigation line to exisitng facilities | 18.75d | 2012-04-14 | 2012-04-30 | Z2.2270 | 128.75d | 0d | SSH-Construction Manhours [10500 h]; Excavator [150 h]; Dump Truck [150 h] | 22,894 |
| Z2.2290 |  | Installation of irrigation line to existing facilities(900LM)A | 31.25d | 2012-05-01 | 2012-05-29 | Z2.2280 | 128.75d | 0d | SSH-Construction Manhours [15000 h] | 57,800 |
| Z2.2300 |  | Installation of irrigation line to existing facilities(900LM)B | 31.25d | 2012-05-30 | 2012-06-27 | Z2.2290 | 128.75d | 32d | SSH-Construction Manhours [15000 h] | 57,800 |
| Z2.2310 |  | Install fire hydrants | 56.25d | 2012-07-28 | 2012-09-18 | Z2.2300, Z2.2320, 1.3.5.1.3.060 | 96.75d | 34.25d | SSH-Construction Manhours [27000 h] | 134,818 |

| ID | WBS | Activity | Duration | Start | Finish | Predecessors | Total float | Free float | Resources | Cost | QTY |
| --- | --- | --- | --- | --- | --- | --- | --- | --- | --- | --- | --- |
|  | 4 | **Zone 4** |  | 2012-06-09 | 2012-10-20 |  |  |  |  |  |  |
|  | 1 | **A4** |  | 2012-06-09 | 2012-10-20 |  |  |  |  |  |  |
| Z4.1110 |  | Excavation for water lineA | 12.5d | 2012-06-09 | 2012-06-19 | Z4.1100, Z4.1180 | 62.5d | 0d | SSH-Construction Manhours [5000 h]; Excavator [100 h]; Dump Truck [100 h] | 4,800 |  |
| Z4.1120 |  | Construction of valve boxes (3) | 31.25d | 2012-06-20 | 2012-07-18 | Z4.1110 | 62.5d | 0d | SSH-Construction Manhours [12500 h] | 39,648 |  |
| Z4.1130 |  | Install PW/FW/CTMU line(180LM)A | 12.5d | 2012-07-19 | 2012-07-30 | Z4.1120 | 62.5d | 0d | SSH-Construction Manhours [7000 h] | 57,800 |  |
| Z4.1170 |  | Install valves | 18.75d | 2012-07-19 | 2012-08-05 | Z4.1120 | 106.25d | 43.75d | SSH-Construction Manhours [15000 h] | 75,000 |  |
| Z4.1140 |  | Excavation for water lineB | 18.75d | 2012-07-31 | 2012-08-16 | Z4.1130 | 62.5d | 0d | SSH-Construction Manhours [6000 h] | 4,800 |  |
| Z4.1150 |  | Install PW/FW/CTMU line(495LM)B | 31.25d | 2012-08-18 | 2012-09-15 | Z4.1140 | 62.5d | 0d | SSH-Construction Manhours [17500 h] | 57,800 |  |
| Z4.1160 |  | Install fire hydrants | 37.5d | 2012-09-16 | 2012-10-20 | Z4.1150, Z4.1170, 1.3.5.1.3.060 | 62.5d | 0d | SSH-Construction Manhours [27000 h] | 50,000 |  |
|  | 4 | **Lift Station Buildings** |  | 2011-08-08 | 2012-10-20 |  |  |  |  |  |  |
|  | 8 | **Lift Station # 9 Zone 4** |  | 2011-09-11 | 2012-10-02 |  |  |  |  |  |  |
|  | 1 | **LS 9 Building - Zone 4** |  | 2011-09-11 | 2012-10-02 |  |  |  |  |  |  |
| 1.4.2.3.5.010 |  | Excavation leveling & compaction for LS9 | 25d | 2011-09-11 | 2011-10-03 | 1.4.2.3.8.010 SS | 56d | 0d | SSH-Construction Manhours [7000 h]; Excavator [100 h]; Dump Truck [100 h] | 15,000 |  |
| 1.4.2.3.5.020 |  | Install lean concrete & water proofing works LS9 | 31.25d | 2011-10-04 | 2011-11-01 | 1.4.2.3.5.010 | 56d | 0d | SSH-Construction Manhours [9000 h] | 32,500 |  |
| 1.4.2.3.5.025 |  | Install Base slab for LS9 | 31.25d | 2011-11-02 | 2011-11-30 | 1.4.2.3.5.020 | 56d | 0d | SSH-Construction Manhours [9000 h] | 20,000 |  |
| 1.4.2.3.5.030 |  | Construction for retaining walls LS9 | 25d | 2011-12-01 | 2011-12-24 | 1.4.2.3.5.010 SS+12.5d, M1.10, M1.12, 1.4.2.3.5.025 | 56d | 0d | SSH-Construction Manhours [9969.72 h] | 4,000 |  |
| 1.4.2.3.5.040 |  | Constrcution for sump pit LS9 | 25d | 2011-12-25 | 2012-01-16 | 1.4.2.3.5.030 | 56d | 0d | SSH-Construction Manhours [30000 h] | 47,000 |  |
| 1.4.2.3.5.050 |  | Construction for top slab LS9 | 31.25d | 2012-01-17 | 2012-02-14 | 1.4.2.3.5.040 | 56d | 0d | SSH-Construction Manhours [30000 h] | 82,250 |  |
| 1.4.2.3.5.060 |  | Construction of wall with water proofing LS9 | 37.5d | 2012-02-09 | 2012-03-14 | 1.4.2.3.5.050 SS+25d, 1.3.1.6.200 | 56d | 0d | SSH-Construction Manhours [36000 h] | 38,750 |  |
| 1.4.2.3.5.070 |  | Backfilling & Compaction LS9 | 25d | 2012-03-13 | 2012-04-04 | 1.4.2.3.5.060 SS+35d | 56d | 0d | SSH-Construction Manhours [12000 h] | 47,000 |  |
| 1.4.2.3.5.080 |  | Plastering & Painting work LS9 -Door installation | 31.25d | 2012-04-05 | 2012-05-03 | 1.4.2.3.5.070, 1.4.2.3.5.020 SS | 56d | 0d | SSH-Construction Manhours [10000 h]; Dump Truck [160 h] | 11,250 |  |
| 1.4.2.3.5.130 |  | Install precast concrete fence & gate LS9 | 30d | 2012-04-23 | 2012-05-21 | 1.4.2.3.5.080 SS+19d | 56d | 0d | SSH-Construction Manhours [9585.81 h] | 200,000 |  |
| 1.4.2.3.5.140 |  | Install asphalt pavement LS9 | 30d | 2012-05-02 | 2012-05-30 | 1.4.2.3.5.130 SS+10d | 56d | 0d | SSH-Construction Manhours [12000 h] | 22,650 |  |
| 1.4.2.3.5.150 |  | Install piping System & odour control system | 30d | 2012-05-30 | 2012-06-27 | 1.4.2.3.5.140, 1.3.5.2.5.030, 1.3.5.2.6.030 | 56d | 0d | SSH-Construction Manhours [12000 h]; Welding Machine [240 h] | 11,000 |  |
| 1.4.2.3.5.155 |  | Install electrical/instr work / fire alarm system in LS9 | 30d | 2012-06-27 | 2012-07-25 | 1.4.2.3.5.150 | 78.5d | 29.5d | SSH-Construction Manhours [12000 h] | 11,000 | 0.003249364 |
| 1.4.2.3.5.160 |  | Testing & Commissioning of LS 9 | 45d | 2012-08-21 | 2012-10-02 | 1.4.2.7.4.108, 1.4.2.3.5.155, Z3.5080, 1.4.3.1.1.570, 1.4.3.1.2.570, M2.10 | 49d | 19d | SSH-Construction Manhours [36000 h] | 88,000 |  |

| ID | WBS | Activity | Duration | Start | Finish | Predecessors | Total float | Free float | Resources | Cost | QTY |
| --- | --- | --- | --- | --- | --- | --- | --- | --- | --- | --- | --- |
|  | 9 | **Lift Station # 10 Zone 3** |  | 2011-08-08 | 2012-10-13 |  |  |  |  |  |  |
|  | 1 | **LS 10 - Building - Zone 3** |  | 2011-08-08 | 2012-10-13 |  |  |  |  |  |  |
| 1.4.2.3.6.010 |  | Excavation leveling & compaction for LS10 | 25d | 2011-08-08 | 2011-08-30 | 1.2.6.200 | 30d | 0d | SSH-Construction Manhours [8000 h]; Excavator [100 h]; Dump Truck [100 h] | 15,000 |  |
| 1.4.2.3.6.020 |  | Install lean concrete & water proofing works LS10 | 31.25d | 2011-08-31 | 2011-09-28 | 1.4.2.3.6.010 | 57.5d | 0d | SSH-Construction Manhours [9000 h] | 32,500 |  |
| 1.4.2.3.6.025 |  | Install base slab for LS10 | 31.25d | 2011-09-29 | 2011-10-27 | 1.4.2.3.6.020 | 57.5d | 0d | SSH-Construction Manhours [9000 h] | 20,000 |  |
| 1.4.2.3.6.030 |  | Construction for retaining walls LS10 | 25d | 2011-10-29 | 2011-11-20 | 1.4.2.3.6.010 SS+12.5d, 1.3.1.1.030 SS, 1.3.1.1.130, 1.4.2.3.6.025 | 57.5d | 0d | SSH-Construction Manhours [9969.72 h] | 4,000 |  |
| 1.4.2.3.6.040 |  | Constrcution for sump pit LS10 | 25d | 2011-11-19 | 2011-12-11 | 1.4.2.3.6.030 SS+22.5d, 1.3.1.6.120 SS | 57.5d | 0d | SSH-Construction Manhours [50000 h] | 53,000 |  |
| 1.4.2.3.6.050 |  | Construction for top slab LS10 | 31.25d | 2011-12-12 | 2012-01-09 | 1.4.2.3.6.040 | 57.5d | 0d | SSH-Construction Manhours [62500 h] | 72,750 |  |
| 1.4.2.3.6.060 |  | Construction of wall with water proofing LS10 | 37.5d | 2012-01-10 | 2012-02-13 | 1.4.2.3.6.050 | 57.5d | 0d | SSH-Construction Manhours [75000 h] | 66,250 |  |
| 1.4.2.3.6.070 |  | Backfilling & Compaction LS10 | 25d | 2012-02-12 | 2012-03-05 | 1.4.2.3.6.060 SS+35d | 57.5d | 0d | SSH-Construction Manhours [8000 h] | 53,000 |  |
| 1.4.2.3.6.080 |  | Plastering & Painting work LS10 -Door installation | 31.25d | 2012-03-06 | 2012-04-03 | 1.4.2.3.6.070 | 57.5d | 0d | SSH-Construction Manhours [17500 h] | 11,250 |  |
| 1.4.2.3.6.130 |  | Install precast concrete fence & gate LS10 | 30d | 2012-03-25 | 2012-04-21 | 1.4.2.3.6.080 SS+20d | 57.5d | 0d | SSH-Construction Manhours [16800 h] | 232,000 |  |
| 1.4.2.3.6.140 |  | Install asphalt pavement LS10 | 30d | 2012-04-22 | 2012-05-19 | 1.4.2.3.6.130 | 57.5d | 20d | SSH-Construction Manhours [7200 h] | 25,350 |  |
| 1.4.2.3.6.150 |  | Install piping system & odour control sytem | 31.25d | 2012-06-07 | 2012-07-05 | 1.4.2.3.6.140, 1.3.5.2.4.030, Z3.2070, Z3.2150, Z3.1140, Z2.2110, Z2.2220, Z2.2340 | 37.5d | 0d | SSH-Construction Manhours [12500 h]; Welding Machine [250 h] | 12,500 |  |
| 1.4.2.3.6.155 |  | Install electrical/instr work/fire detection system LS10 | 31.25d | 2012-07-07 | 2012-08-04 | 1.4.2.3.6.150 | 67.5d | 30d | SSH-Construction Manhours [12500 h] | 12,500 | 0.0036924591 |
| 1.4.2.3.6.160 |  | Testing & Commissioning of LS 10 | 45d | 2012-09-02 | 2012-10-13 | 1.4.2.7.4.102, 1.4.2.3.6.155, 1.4.3.1.1.570, 1.4.3.1.2.570, M2.10 | 37.5d | 7.5d | SSH-Construction Manhours [18000 h] | 80,000 |  |
|  | 10 | **Lift Station # 11 Zone 3** |  | 2011-08-31 | 2012-10-20 |  |  |  |  |  |  |
|  | 1 | **LS 11 - Building - Zone 3** |  | 2011-08-31 | 2012-10-20 |  |  |  |  |  |  |
| 1.4.2.3.7.010 |  | Excavation leveling & compaction for LS11 | 25d | 2011-08-31 | 2011-09-22 | 1.4.2.3.6.010 | 30d | 0d | SSH-Construction Manhours [8000 h]; Excavator [100 h]; Dump Truck [100 h] | 15,000 |  |
| 1.4.2.3.7.020 |  | Install lean concrete & water proofing works LS11 | 31.25d | 2011-09-24 | 2011-10-22 | 1.4.2.3.7.010 | 30d | 0d | SSH-Construction Manhours [9000 h] | 32,500 |  |
| 1.4.2.3.7.025 |  | Install base slab for LS11 | 31.25d | 2011-10-23 | 2011-11-20 | 1.4.2.3.7.020 | 30d | 0d | SSH-Construction Manhours [9000 h] | 20,000 |  |
| 1.4.2.3.7.030 |  | Construction for retaining walls LS11 | 25d | 2011-11-21 | 2011-12-13 | 1.4.2.3.7.025 | 30d | 0d | SSH-Construction Manhours [9969.72 h] | 4,000 |  |
| 1.4.2.3.7.040 |  | Constrcution for sump pit LS11 | 25d | 2011-12-08 | 2011-12-31 | 1.4.2.3.7.030 SS+18.75d | 30d | 0d | SSH-Construction Manhours [50000 h] | 47,000 |  |
| 1.4.2.3.7.050 |  | Construction for top slab LS11 | 31.25d | 2012-01-01 | 2012-01-29 | 1.4.2.3.7.040 | 30d | 0d | SSH-Construction Manhours [37500 h] | 62,250 |  |
| 1.4.2.3.7.060 |  | Construction of wall with water proofing LS11 | 37.5d | 2012-02-02 | 2012-03-07 | 1.4.2.3.7.050 SS+35d | 30d | 0d | SSH-Construction Manhours [45000 h] | 58,750 |  |
| 1.4.2.3.7.070 |  | Backfilling & Compaction LS11 | 25d | 2012-03-06 | 2012-03-28 | 1.4.2.3.7.060 SS+35d | 30d | 0d | SSH-Construction Manhours [14000 h] | 47,000 |  |
| 1.4.2.3.7.080 |  | Plastering & Painting work LS11 -Door installation | 20d | 2012-03-29 | 2012-04-16 | 1.4.2.3.7.070, 1.4.2.3.7.020 SS | 30d | 0d | SSH-Construction Manhours [8000 h]; Dump Truck [160 h] | 11,250 |  |
| 1.4.2.3.7.130 |  | Install precast concrete fence & gate LS11 | 30d | 2012-04-17 | 2012-05-14 | 1.4.2.3.7.080 | 30d | 0d | SSH-Construction Manhours [12000 h] | 200,000 |  |
| 1.4.2.3.7.140 |  | Install asphalt pavement LS11 | 25d | 2012-05-15 | 2012-06-06 | 1.4.2.3.7.130 | 30d | 0d | SSH-Construction Manhours [10000 h] | 22,650 |  |
| 1.4.2.3.7.150 |  | Install piping System & odour control system | 31.25d | 2012-06-07 | 2012-07-05 | 1.4.2.3.7.140 | 30d | 0d | SSH-Construction Manhours [12500 h]; Welding Machine [250 h] | 11,000 |  |
| 1.4.2.3.7.155 |  | Install electrical/instr work / fire alarm system LS11 | 31.25d | 2012-07-07 | 2012-08-04 | 1.4.2.3.7.150 | 68.75d | 38.75d | SSH-Construction Manhours [12500 h] | 11,000 | 0.003249364 |
| 1.4.2.3.7.160 |  | Testing & Commissioning of LS 11 | 43.75d | 2012-09-10 | 2012-10-20 | 1.4.2.7.4.104, 1.4.2.3.7.155, 1.4.3.1.1.570, 1.4.3.1.2.570, M2.10 | 30d | 0d | SSH-Construction Manhours [25000 h] | 88,000 |  |

| ID | WBS | Activity | Duration | Start | Finish | Predecessors | Total float | Free float | Resources | Cost | QTY |
| --- | --- | --- | --- | --- | --- | --- | --- | --- | --- | --- | --- |
|  | 11 | **Lift Station #12 Zone 2** |  | 2011-09-11 | 2012-10-18 |  |  |  |  |  |  |
|  | 1 | **LS 12 - Building - Zone 2** |  | 2011-09-11 | 2012-10-18 |  |  |  |  |  |  |
| 1.4.2.3.8.010 |  | Excavation leveling & compaction for LS12 | 25d | 2011-09-11 | 2011-10-03 | 1.4.2.3.7.010 SS+11.25d | 31.25d | 0d | SSH-Construction Manhours [8000 h]; Excavator [100 h]; Dump Truck [100 h] | 15,000 |  |
| 1.4.2.3.8.020 |  | Install lean concrete & water proofing works LS12 | 31.25d | 2011-10-04 | 2011-11-01 | 1.4.2.3.8.010 | 31.25d | 0d | SSH-Construction Manhours [9000 h] | 32,500 |  |
| 1.4.2.3.8.025 |  | Install base slab for LS12 | 31.25d | 2011-11-02 | 2011-11-30 | 1.4.2.3.8.020 | 31.25d | 0d | SSH-Construction Manhours [9000 h] | 20,000 |  |
| 1.4.2.3.8.030 |  | Construction for retaining walls LS12 | 25d | 2011-12-01 | 2011-12-24 | 1.4.2.3.8.025 | 31.25d | 0d | SSH-Construction Manhours [9969.72 h] | 4,000 |  |
| 1.4.2.3.8.040 |  | Constrcution for sump pit LS12 | 25d | 2011-12-22 | 2012-01-14 | 1.4.2.3.8.030 SS+22.5d | 31.25d | 0d | SSH-Construction Manhours [50000 h] | 53,000 |  |
| 1.4.2.3.8.050 |  | Construction for top slab LS12 | 31.25d | 2012-01-15 | 2012-02-12 | 1.4.2.3.8.040 | 31.25d | 0d | SSH-Construction Manhours [50000 h] | 92,750 |  |
| 1.4.2.3.8.060 |  | Construction of wall with water proofing LS12 | 31.25d | 2012-02-13 | 2012-03-12 | 1.4.2.3.8.050 | 31.25d | 0d | SSH-Construction Manhours [37500 h] | 46,250 |  |
| 1.4.2.3.8.070 |  | Backfilling & Compaction LS12 | 25d | 2012-03-13 | 2012-04-04 | 1.4.2.3.8.060 | 31.25d | 0d | SSH-Construction Manhours [8000 h] | 53,000 |  |
| 1.4.2.3.8.080 |  | Plastering & Painting work LS11 -Door installation | 20d | 2012-04-05 | 2012-04-23 | 1.4.2.3.8.070, 1.4.2.3.8.020 SS | 31.25d | 0d | SSH-Construction Manhours [8000 h]; Dump Truck [160 h] | 11,250 |  |
| 1.4.2.3.8.130 |  | Install precast concrete fence & gate LS12 | 30d | 2012-04-24 | 2012-05-21 | 1.4.2.3.8.080 | 31.25d | 0d | SSH-Construction Manhours [12000 h] | 232,000 |  |
| 1.4.2.3.8.140 |  | Install asphalt pavement LS12 | 30d | 2012-05-22 | 2012-06-18 | 1.4.2.3.8.130 | 31.25d | 0d | SSH-Construction Manhours [9600 h] | 25,000 |  |
| 1.4.2.3.8.150 |  | Install piping System & odour control system | 43.75d | 2012-06-19 | 2012-07-29 | 1.4.2.3.8.140 | 31.25d | 0d | SSH-Construction Manhours [12500 h]; Welding Machine [350 h] | 12,675 |  |
| 1.4.2.3.8.155 |  | Install electrical/instr work / fire alarm system LS12 | 31.25d | 2012-07-30 | 2012-08-27 | 1.4.2.3.8.150 | 31.25d | 0d | SSH-Construction Manhours [19200 h] | 12,675 | 0.0037441535 |
| 1.4.2.3.8.160 |  | Testing & Commissioning of LS 12 | 56.25d | 2012-08-28 | 2012-10-18 | 1.4.2.7.4.106, 1.4.2.3.8.155, 1.4.3.1.1.570, 1.4.3.1.2.570, M2.10 | 31.25d | 1.25d | SSH-Construction Manhours [25500 h] | 80,000 |  |
|  | 5 | **Storm water drainage system** |  | 2012-01-28 | 2012-10-20 |  |  |  |  |  |  |
|  | 1 | **Zone 1** |  | 2012-04-12 | 2012-06-30 |  |  |  |  |  |  |
|  | 1 | **Storm Drainage Ditches** |  | 2012-04-12 | 2012-06-30 |  |  |  |  |  |  |
| 1.4.2.4.1.010 |  | Excavation for storm water drainage ditch (750LM) | 25d | 2012-04-12 | 2012-05-05 | 1.4.2.4.2.090A SS+25d | 80d | 0d | SSH-Construction Manhours [8000 h] | 9,000 |  |
| 1.4.2.4.1.020 |  | Construction of concrete drainage ditch | 25d | 2012-05-03 | 2012-05-26 | 1.4.2.4.1.010 SS+22.5d | 182.5d | 0d | SSH-Construction Manhours [10000 h] | 154,500 |  |
| 1.4.2.4.1.015 |  | Leveling -compaction of drainage ditch | 31.25d | 2012-06-02 | 2012-06-30 | 1.4.2.4.1.020 SS+31.25d | 182.5d | 120d | SSH-Construction Manhours [10000 h] | 12,000 | 0.0035447607 |
|  | 2 | **Zone 2** |  | 2012-03-20 | 2012-10-20 |  |  |  |  |  |  |
|  | 1 | **Storm Drainage Ditches** |  | 2012-03-20 | 2012-08-20 |  |  |  |  |  |  |
| 1.4.2.4.2.090A |  | Excavation for storm water drainage ditch (2550LM)A | 10d | 2012-03-20 | 2012-03-28 | Z2.1100 | 62.5d | 0d | SSH-Construction Manhours [3200 h] | 11,250 |  |
| 1.4.2.4.2.090B |  | Leveling - compaction of drainage ditchA | 12.5d | 2012-03-29 | 2012-04-09 | 1.4.2.4.2.090A | 127.5d | 0d | SSH-Construction Manhours [4000 h] | 15,000 |  |
| 1.4.2.4.2.090C |  | Construction of concrete drainage ditchA | 18.75d | 2012-04-10 | 2012-04-26 | 1.4.2.4.2.090B | 127.5d | 0d | SSH-Construction Manhours [7500 h] | 193,125 |  |
| 1.4.2.4.2.091A |  | Excavation for storm water drainage ditch (2550LM)B | 10d | 2012-04-28 | 2012-05-06 | 1.4.2.4.2.090C | 127.5d | 0d | SSH-Construction Manhours [3200 h] | 11,250 |  |
| 1.4.2.4.2.091B |  | Leveling - compaction of drainage ditchB | 12.5d | 2012-05-07 | 2012-05-17 | 1.4.2.4.2.091A | 127.5d | 0d | SSH-Construction Manhours [4000 h] | 15,000 |  |
| 1.4.2.4.2.091C |  | Construction of concrete drainage ditchB | 18.75d | 2012-05-19 | 2012-06-04 | 1.4.2.4.2.091B | 127.5d | 0d | SSH-Construction Manhours [7500 h] | 193,125 |  |
| 1.4.2.4.2.092A |  | Excavation for storm water drainage ditch (2550LM)C | 10d | 2012-06-05 | 2012-06-13 | 1.4.2.4.2.091C | 127.5d | 0d | SSH-Construction Manhours [3200 h] | 11,250 |  |
| 1.4.2.4.2.092B |  | Leveling - compaction of drainage ditchC | 12.5d | 2012-06-14 | 2012-06-25 | 1.4.2.4.2.092A | 127.5d | 0d | SSH-Construction Manhours [4000 h] | 15,000 |  |
| 1.4.2.4.2.092D |  | Construction of concrete drainage ditchC | 18.75d | 2012-06-26 | 2012-07-12 | 1.4.2.4.2.092B | 127.5d | 0d | SSH-Construction Manhours [6000 h] | 193,125 |  |
| 1.4.2.4.2.093A |  | Excavation for storm water drainage ditch (2550LM)D | 10d | 2012-07-14 | 2012-07-22 | 1.4.2.4.2.092D | 127.5d | 0d | SSH-Construction Manhours [3200 h] | 11,250 |  |
| 1.4.2.4.2.093B |  | Leveling - compaction of drainage ditchD | 12.5d | 2012-07-23 | 2012-08-02 | 1.4.2.4.2.093A | 127.5d | 0d | SSH-Construction Manhours [4000 h] | 15,000 |  |
| 1.4.2.4.2.093C |  | Construction of concrete drainage ditchD | 18.75d | 2012-08-04 | 2012-08-20 | 1.4.2.4.2.093B | 127.5d | 65d | SSH-Construction Manhours [7500 h] | 193,124 |  |

| ID | WBS | Activity | Duration | Start | Finish | Predecessors | Total float | Free float | Resources | Cost |
| --- | --- | --- | --- | --- | --- | --- | --- | --- | --- | --- |
|  | 2 | **Strom Drainage Ponds & Box Culverts** |  | 2012-03-20 | 2012-10-20 |  |  |  |  |  |
| 1.4.2.4.2.010 |  | Excavation for storm water drainage pond | 10d | 2012-03-20 | 2012-03-28 | 1.4.2.4.2.090A SS | 62.5d | 0d | SSH-Construction Manhours [3200 h]; Excavator [80 h]; Dump Truck [80 h] | 199,889 |
| 1.4.2.4.2.050A |  | Excavation for Box culvert-1 | 7.5d | 2012-03-20 | 2012-03-26 | 1.4.2.4.2.010 SS | 62.5d | 0d | SSH-Construction Manhours [2400 h] | 18,000 |
| 1.4.2.4.2.050B |  | Leveling -compaction of box culvert-1 | 7.5d | 2012-03-27 | 2012-04-02 | 1.4.2.4.2.050A | 62.5d | 0d | SSH-Construction Manhours [2400 h] | 5,000 |
| 1.4.2.4.2.020 |  | Construction of RC spillways | 25d | 2012-03-29 | 2012-04-21 | 1.4.2.4.2.010 | 212.5d | 0d | SSH-Construction Manhours [16000 h] | 150,000 |
| 1.4.2.4.2.050C |  | Construction of box culvert-1 | 43.75d | 2012-04-03 | 2012-05-13 | 1.4.2.4.2.050B | 62.5d | 0d | SSH-Construction Manhours [70000 h] | 150,000 |
| 1.4.2.4.2.015 |  | Leveling - compaction for drainage pond | 12.5d | 2012-04-22 | 2012-05-02 | 1.4.2.4.2.020 | 212.5d | 0d | SSH-Construction Manhours [4000 h] | 120,000 |
| 1.4.2.4.2.040 |  | Marl caping for drainage pond | 25d | 2012-05-10 | 2012-06-02 | 1.4.2.4.2.015 SS+20d | 212.5d | 150d | SSH-Construction Manhours [8000 h] | 125,000 |
| 1.4.2.4.2.051A |  | Excavation for Box culvert-2 | 7.5d | 2012-05-14 | 2012-05-20 | 1.4.2.4.2.050C | 62.5d | 0d | SSH-Construction Manhours [2400 h] | 18,000 |
| 1.4.2.4.2.051B |  | Leveling -compaction of box culvert-2 | 7.5d | 2012-05-21 | 2012-05-27 | 1.4.2.4.2.051A | 62.5d | 0d | SSH-Construction Manhours [2400 h] | 5,000 |
| 1.4.2.4.2.051C |  | Construction of box culvert-2 | 43.75d | 2012-05-28 | 2012-07-07 | 1.4.2.4.2.051B | 62.5d | 0d | SSH-Construction Manhours [12500 h] | 150,000 |
| 1.4.2.4.2.052A |  | Excavation for Box culvert-3 | 7.5d | 2012-07-08 | 2012-07-14 | 1.4.2.4.2.051C | 62.5d | 0d | SSH-Construction Manhours [2400 h] | 18,000 |
| 1.4.2.4.2.052B |  | Leveling -compaction of box culvert-3 | 7.5d | 2012-07-15 | 2012-07-21 | 1.4.2.4.2.052A | 62.5d | 0d | SSH-Construction Manhours [2400 h] | 5,000 |
| 1.4.2.4.2.052C |  | Construction of box culvert-3 | 43.75d | 2012-07-22 | 2012-08-30 | 1.4.2.4.2.052B | 62.5d | 0d | SSH-Construction Manhours [10000 h] | 150,000 |
| 1.4.2.4.2.053A |  | Excavation for Box culvert-4 | 7.5d | 2012-09-01 | 2012-09-06 | 1.4.2.4.2.052C | 62.5d | 0d | SSH-Construction Manhours [2400 h] | 18,000 |
| 1.4.2.4.2.054A |  | Excavation for Box culvert-5 | 7.5d | 2012-09-01 | 2012-09-06 | 1.4.2.4.2.053A SS | 62.5d | 0d | SSH-Construction Manhours [2400 h] | 18,000 |
| 1.4.2.4.2.053B |  | Leveling -compaction of box culvert-4 | 7.5d | 2012-09-08 | 2012-09-13 | 1.4.2.4.2.053A | 62.5d | 0d | SSH-Construction Manhours [2400 h] | 5,000 |
| 1.4.2.4.2.054B |  | Leveling -compaction of box culvert-5 | 7.5d | 2012-09-08 | 2012-09-13 | 1.4.2.4.2.054A | 62.5d | 0d | SSH-Construction Manhours [2400 h] | 5,000 |
| 1.4.2.4.2.053C |  | Construction of box culvert-4 | 38.75d | 2012-09-15 | 2012-10-20 | 1.4.2.4.2.053B | 62.5d | 0d | SSH-Construction Manhours [8500 h] | 150,000 |
| 1.4.2.4.2.054C |  | Construction of box culvert-5 | 38.75d | 2012-09-15 | 2012-10-20 | 1.4.2.4.2.054B | 62.5d | 0d | SSH-Construction Manhours [8500 h] | 150,000 |
|  | 3 | **Zone 3** |  | 2012-01-28 | 2012-10-20 |  |  |  |  |  |
|  | 1 | **Storm Drainage Ditches-A3-1** |  | 2012-01-28 | 2012-06-20 |  |  |  |  |  |
| 1.4.2.4.3.090A |  | Excavation for storm water drainage ditchA3-1-1 | 7.5d | 2012-01-28 | 2012-02-04 | 1.4.2.7.3.030 SS+31.25d | 62.75d | 0d | SSH-Construction Manhours [3600 h] | 84,063 |
| 1.4.2.4.3.090B |  | Leveling -compaction of drainage ditchA3-1-1 | 12.5d | 2012-02-04 | 2012-02-15 | 1.4.2.4.3.090A | 66.5d | 0d | SSH-Construction Manhours [6000 h] | 42,547 |
| 1.4.2.4.3.090C |  | Construction of concrete drainage ditchA3-1-1 | 18.75d | 2012-02-15 | 2012-03-04 | 1.4.2.4.3.090B | 66.5d | 0d | SSH-Construction Manhours [9000 h] | 298,811 |
| 1.4.2.4.3.092A |  | Excavation for storm water drainage ditchA3-1-2 | 7.5d | 2012-03-04 | 2012-03-11 | 1.4.2.4.3.090C | 66.5d | 0d | SSH-Construction Manhours [2400 h] | 84,063 |
| 1.4.2.4.3.092B |  | Leveling -compaction of drainage ditchA3-1-2 | 12.5d | 2012-03-11 | 2012-03-22 | 1.4.2.4.3.092A | 66.5d | 0d | SSH-Construction Manhours [4000 h] | 42,547 |
| 1.4.2.4.3.092C |  | Construction of concrete drainage ditchA3-1-2 | 18.75d | 2012-03-22 | 2012-04-09 | 1.4.2.4.3.092B | 66.5d | 0d | SSH-Construction Manhours [7500 h] | 298,811 |
| 1.4.2.4.3.094A |  | Excavation for storm water drainage ditchA3-1-3 | 7.5d | 2012-04-09 | 2012-04-16 | 1.4.2.4.3.092C | 66.5d | 0d | SSH-Construction Manhours [2400 h] | 84,063 |
| 1.4.2.4.3.094B |  | Leveling -compaction of drainage ditchA3-1-3 | 12.5d | 2012-04-16 | 2012-04-28 | 1.4.2.4.3.094A | 66.5d | 0d | SSH-Construction Manhours [4000 h] | 42,547 |
| 1.4.2.4.3.094C |  | Construction of concrete drainage ditchA3-1-3 | 18.75d | 2012-04-28 | 2012-05-15 | 1.4.2.4.3.094B | 66.5d | 0d | SSH-Construction Manhours [7500 h] | 298,811 |
| 1.4.2.4.3.096A |  | Excavation for storm water drainage ditchA3-1-4 | 7.5d | 2012-05-15 | 2012-05-22 | 1.4.2.4.3.094C | 66.5d | 0d | SSH-Construction Manhours [2400 h] | 84,063 |
| 1.4.2.4.3.096B |  | Leveling -compaction of drainage ditchA3-1-4 | 12.5d | 2012-05-22 | 2012-06-03 | 1.4.2.4.3.096A | 66.5d | 0d | SSH-Construction Manhours [4000 h] | 42,547 |
| 1.4.2.4.3.096C |  | Construction of concrete drainage ditchA3-1-4 | 18.75d | 2012-06-03 | 2012-06-20 | 1.4.2.4.3.096B | 66.5d | 0d | SSH-Construction Manhours [7500 h] | 298,811 |

| ID | WBS | Activity | Duration | Start | Finish | Predecessors | Total float | Free float | Resources | Cost |
| --- | --- | --- | --- | --- | --- | --- | --- | --- | --- | --- |
|  | 2 | **Strom Drainage Ponds-A3-1** |  | 2012-06-20 | 2012-10-16 |  |  |  |  |  |
| 1.4.2.4.3.010 |  | Excavation for storm water drainage pond (1) | 7.5d | 2012-06-20 | 2012-06-27 | 1.4.2.4.3.096C | 66.5d | 0d | SSH-Construction Manhours [3000 h]; Excavator [60 h]; Dump Truck [60 h] | 84,063 |
| 1.4.2.4.3.015 |  | Leveling- compaction for drainage pond | 15d | 2012-06-27 | 2012-07-11 | 1.4.2.4.3.010 | 66.5d | 0d | SSH-Construction Manhours [6000 h] | 42,547 |
| 1.4.2.4.3.020 |  | Construction of RC spillwaysA | 25d | 2012-07-11 | 2012-08-04 | 1.4.2.4.3.015 | 66.5d | 0d | SSH-Construction Manhours [12000 h] | 49,405 |
| 1.4.2.4.3.030 |  | Construction of RC spillwaysB | 25d | 2012-08-04 | 2012-08-27 | 1.4.2.4.3.020 | 66.5d | 0d | SSH-Construction Manhours [12000 h] | 49,406 |
| 1.4.2.4.3.040 |  | Marl caping for drainage pond | 25d | 2012-08-27 | 2012-09-19 | 1.4.2.4.3.020, 1.4.2.4.3.030 | 66.5d | 0d | SSH-Construction Manhours [8000 h] | 360,000 |
| 1.4.2.4.3.050 |  | Excavation for Box culvert | 7.5d | 2012-08-27 | 2012-09-03 | 1.4.2.4.3.040 SS | 66.5d | 0d | SSH-Construction Manhours [2400 h] | 30,000 |
| 1.4.2.4.3.060 |  | Leveling -compaction of box culvert | 7.5d | 2012-09-03 | 2012-09-10 | 1.4.2.4.3.050 | 66.5d | 0d | SSH-Construction Manhours [2400 h] | 20,000 |
| 1.4.2.4.3.070 |  | Construction of box culvert | 38.75d | 2012-09-10 | 2012-10-16 | 1.4.2.4.3.060 | 66.5d | 4d | SSH-Construction Manhours [8500 h] | 100,000 |
|  | 3 | **Storm Drainage Ditches-A3-2** |  | 2012-02-04 | 2012-09-03 |  |  |  |  |  |
| 1.4.2.4.3.100A |  | Excavation for storm water drainage ditchA3-2.-1 | 18.75d | 2012-02-04 | 2012-02-21 | 1.4.2.4.3.090A | 62.75d | 0d | SSH-Construction Manhours [6000 h] | 84,063 |
| 1.4.2.4.3.100B |  | Leveling -compaction of drainage ditchA3-2-1 | 15d | 2012-02-21 | 2012-03-06 | 1.4.2.4.3.100A | 112.75d | 0d | SSH-Construction Manhours [4800 h] | 42,547 |
| 1.4.2.4.3.100C |  | Construction of concrete drainage ditchA3-2-1 | 25d | 2012-03-06 | 2012-03-29 | 1.4.2.4.3.100B | 112.75d | 0d | SSH-Construction Manhours [10000 h] | 298,811 |
| 1.4.2.4.3.102A |  | Excavation for storm water drainage ditchA3-2-2 | 18.75d | 2012-03-29 | 2012-04-16 | 1.4.2.4.3.100C | 112.75d | 0d | SSH-Construction Manhours [6000 h] | 84,063 |
| 1.4.2.4.3.102B |  | Leveling -compaction of drainage ditchA3-2-2 | 12.5d | 2012-04-16 | 2012-04-28 | 1.4.2.4.3.102A | 112.75d | 0d | SSH-Construction Manhours [4000 h] | 42,547 |
| 1.4.2.4.3.102C |  | Construction of concrete drainage ditchA3-2-2 | 25d | 2012-04-28 | 2012-05-21 | 1.4.2.4.3.102B | 112.75d | 0d | SSH-Construction Manhours [10000 h] | 298,811 |
| 1.4.2.4.3.104A |  | Excavation for storm water drainage ditchA3-2-3 | 18.75d | 2012-05-21 | 2012-06-07 | 1.4.2.4.3.102C | 112.75d | 0d | SSH-Construction Manhours [6000 h] | 84,063 |
| 1.4.2.4.3.104B |  | Leveling -compaction of drainage ditchA3-2-3 | 12.5d | 2012-06-07 | 2012-06-19 | 1.4.2.4.3.104A | 112.75d | 0d | SSH-Construction Manhours [7000 h] | 42,547 |
| 1.4.2.4.3.104C |  | Construction of concrete drainage ditchA3-2-3 | 25d | 2012-06-19 | 2012-07-12 | 1.4.2.4.3.104B | 112.75d | 0d | SSH-Construction Manhours [10000 h] | 298,811 |
| 1.4.2.4.3.106A |  | Excavation for storm water drainage ditchA3-2-4 | 18.75d | 2012-07-12 | 2012-07-30 | 1.4.2.4.3.104C | 112.75d | 0d | SSH-Construction Manhours [7500 h] | 84,063 |
| 1.4.2.4.3.106B |  | Leveling -compaction of drainage ditchA3-2-4 | 12.5d | 2012-07-30 | 2012-08-11 | 1.4.2.4.3.106A | 112.75d | 0d | SSH-Construction Manhours [5000 h] | 42,547 |
| 1.4.2.4.3.106C |  | Construction of concrete drainage ditchA3-2-4 | 25d | 2012-08-11 | 2012-09-03 | 1.4.2.4.3.106B | 112.75d | 50.25d | SSH-Construction Manhours [12000 h] | 298,811 |
|  | 5 | **Storm Drainage Ditches & Box Culvert -A3-3** |  | 2012-02-21 | 2012-09-10 |  |  |  |  |  |
| 1.4.2.4.3.110A |  | Excavation for storm water drainage ditchA3-3-1 | 18.75d | 2012-02-21 | 2012-03-10 | 1.4.2.4.3.100A | 62.75d | 0d | SSH-Construction Manhours [6000 h] | 84,063 |
| 1.4.2.4.3.110B |  | Leveling -compaction of drainage ditchA3-3-1 | 15d | 2012-03-10 | 2012-03-24 | 1.4.2.4.3.110A | 62.75d | 0d | SSH-Construction Manhours [4800 h] | 42,547 |
| 1.4.2.4.3.110C |  | Construction of concrete drainage ditchA3-3-1 | 25d | 2012-03-24 | 2012-04-16 | 1.4.2.4.3.110B | 62.75d | 0d | SSH-Construction Manhours [10000 h] | 298,811 |
| 1.4.2.4.3.112A |  | Excavation for storm water drainage ditchA3-3-2 | 18.75d | 2012-04-16 | 2012-05-03 | 1.4.2.4.3.110C | 62.75d | 0d | SSH-Construction Manhours [6000 h] | 84,063 |
| 1.4.2.4.3.112B |  | Leveling -compaction of drainage ditchA3-3-2 | 12.5d | 2012-05-03 | 2012-05-15 | 1.4.2.4.3.112A | 62.75d | 0d | SSH-Construction Manhours [4000 h] | 42,547 |
| 1.4.2.4.3.112C |  | Construction of concrete drainage ditchA3-3-2 | 25d | 2012-05-15 | 2012-06-07 | 1.4.2.4.3.112B | 62.75d | 0d | SSH-Construction Manhours [10000 h] | 298,811 |
| 1.4.2.4.3.114A |  | Excavation for storm water drainage ditchA3-3-3 | 18.75d | 2012-06-07 | 2012-06-25 | 1.4.2.4.3.112C | 62.75d | 0d | SSH-Construction Manhours [6000 h] | 84,063 |
| 1.4.2.4.3.114B |  | Leveling -compaction of drainage ditchA3-3-3 | 12.5d | 2012-06-25 | 2012-07-07 | 1.4.2.4.3.114A | 105.25d | 0d | SSH-Construction Manhours [4000 h] | 42,547 |
| 1.4.2.4.3.114C |  | Construction of concrete drainage ditchA3-3-3 | 25d | 2012-07-07 | 2012-07-30 | 1.4.2.4.3.114B | 105.25d | 0d | SSH-Construction Manhours [10000 h] | 298,811 |
| 1.4.2.4.3.116A |  | Excavation for storm water drainage ditchA3-3-4 | 18.75d | 2012-07-30 | 2012-08-16 | 1.4.2.4.3.114C | 105.25d | 0d | SSH-Construction Manhours [6000 h] | 84,063 |
| 1.4.2.4.3.116B |  | Leveling -compaction of drainage ditchA3-3-4 | 12.5d | 2012-08-16 | 2012-08-28 | 1.4.2.4.3.116A | 105.25d | 0d | SSH-Construction Manhours [4000 h] | 42,547 |
| 1.4.2.4.3.116C |  | Construction of concrete drainage ditchA3-3-4 | 21.25d | 2012-08-21 | 2012-09-10 | 1.4.2.4.3.116B SS+5d | 105.25d | 42.75d | SSH-Construction Manhours [6800 h] | 298,811 |

| ID | WBS | Activity | Duration | Start | Finish | Predecessors | Total float | Free float | Resources | Cost |
| --- | --- | --- | --- | --- | --- | --- | --- | --- | --- | --- |
|  | 6 | **Strom Drainage Ponds -A3-3** |  | 2012-06-07 | 2012-10-20 |  |  |  |  |  |
| 1.4.2.4.3.310 |  | Excavation for storm water drainage pond (1) | 7.5d | 2012-06-07 | 2012-06-14 | 1.4.2.4.3.114A SS | 62.75d | 0d | SSH-Construction Manhours [4200 h]; Dump Truck [60 h]; Excavator [60 h] | 42,031 |
| 1.4.2.4.3.320 |  | Leveling- compaction for drainage pond | 10d | 2012-06-14 | 2012-06-24 | 1.4.2.4.3.310 | 62.75d | 0d | SSH-Construction Manhours [4000 h] | 21,273 |
| 1.4.2.4.3.330 |  | Construction of RC spillways | 25d | 2012-06-24 | 2012-07-17 | 1.4.2.4.3.320 | 62.75d | 0d | SSH-Construction Manhours [16000 h] | 99,405 |
| 1.4.2.4.3.340 |  | Marl caping for drainage pond | 10d | 2012-07-17 | 2012-07-26 | 1.4.2.4.3.330 | 62.75d | 0d | SSH-Construction Manhours [24000 h] | 831 |
| 1.4.2.4.3.350 |  | Excavation for storm water drainage pond (2) | 7.5d | 2012-07-26 | 2012-08-02 | 1.4.2.4.3.340 | 62.75d | 0d | SSH-Construction Manhours [4200 h] | 42,032 |
| 1.4.2.4.3.360 |  | Leveling- compaction for drainage pond | 7.5d | 2012-08-02 | 2012-08-09 | 1.4.2.4.3.350 | 62.75d | 0d | SSH-Construction Manhours [4200 h] | 21,275 |
| 1.4.2.4.3.370 |  | Construction of RC spillways | 25d | 2012-08-09 | 2012-09-02 | 1.4.2.4.3.360 | 62.75d | 0d | SSH-Construction Manhours [12000 h] | 99,406 |
| 1.4.2.4.3.380 |  | Marl caping for drainage pond | 10d | 2012-09-02 | 2012-09-11 | 1.4.2.4.3.370 | 62.75d | 0d | SSH-Construction Manhours [24000 h] | 831 |
| 1.4.2.4.3.390 |  | Excavation for Box culvert | 7.5d | 2012-09-02 | 2012-09-09 | 1.4.2.4.3.380 SS | 62.75d | 0d | SSH-Construction Manhours [2400 h] | 30,000 |
| 1.4.2.4.3.400 |  | Leveling -compaction of box culvert | 7.5d | 2012-09-09 | 2012-09-16 | 1.4.2.4.3.390 | 62.75d | 0d | SSH-Construction Manhours [2400 h] | 20,000 |
| 1.4.2.4.3.450 |  | Construction of box culvert | 36.25d | 2012-09-16 | 2012-10-20 | 1.4.2.4.3.400 | 62.75d | 0.25d | SSH-Construction Manhours [8500 h] | 100,000 |
|  | 7 | **Strom Drainage Ponds -A3-4** |  | 2012-06-07 | 2012-10-10 |  |  |  |  |  |
| 1.4.2.4.3.410 |  | Excavation for storm water drainage ditchA | 12.5d | 2012-06-07 | 2012-06-19 | 1.4.2.4.3.310 SS | 72.75d | 0d | SSH-Construction Manhours [4200 h]; Excavator [60 h]; Dump Truck [60 h] | 42,862 |
| 1.4.2.4.3.420 |  | Leveling -compaction of drainage ditchA | 12.5d | 2012-06-19 | 2012-07-01 | 1.4.2.4.3.410 | 72.75d | 0d | SSH-Construction Manhours [4000 h] | 21,273 |
| 1.4.2.4.3.430 |  | Construction of concrete drainage ditchA | 25d | 2012-07-01 | 2012-07-24 | 1.4.2.4.3.420 | 72.75d | 0d | SSH-Construction Manhours [16000 h] | 74,405 |
| 1.4.2.4.3.440 |  | Excavation for storm water drainage ditchB | 12.5d | 2012-07-24 | 2012-08-05 | 1.4.2.4.3.430 | 72.75d | 0d | SSH-Construction Manhours [3200 h] | 42,863 |
| 1.4.2.4.3.460 |  | Leveling -compaction of drainage ditchB | 12.5d | 2012-08-05 | 2012-08-16 | 1.4.2.4.3.440 | 72.75d | 0d | SSH-Construction Manhours [4000 h] | 21,274 |
| 1.4.2.4.3.470 |  | Construction of concrete drainage ditchB | 25d | 2012-08-16 | 2012-09-09 | 1.4.2.4.3.460 | 72.75d | 0d | SSH-Construction Manhours [16000 h] | 74,406 |
| 1.4.2.4.3.480 |  | Excavation for Box culvert A | 7.5d | 2012-08-16 | 2012-08-23 | 1.4.2.4.3.470 SS | 72.75d | 0d | SSH-Construction Manhours [2400 h] | 22,500 |
| 1.4.2.4.3.490 |  | Leveling -compaction of box culvertA | 7.5d | 2012-08-23 | 2012-08-30 | 1.4.2.4.3.480 | 77.75d | 0d | SSH-Construction Manhours [2400 h] | 15,000 |
| 1.4.2.4.3.510 |  | Excavation for Box culvert B | 7.5d | 2012-08-23 | 2012-08-30 | 1.4.2.4.3.480 | 72.75d | 0d | SSH-Construction Manhours [2400 h] | 22,500 |
| 1.4.2.4.3.500 |  | Construction of box culvertA | 38.75d | 2012-08-30 | 2012-10-06 | 1.4.2.4.3.490 | 77.75d | 15.25d | SSH-Construction Manhours [8500 h] | 37,500 |
| 1.4.2.4.3.520 |  | Leveling -compaction of box culvertB | 7.5d | 2012-08-30 | 2012-09-06 | 1.4.2.4.3.510 | 72.75d | 0d | SSH-Construction Manhours [2400 h] | 15,000 |
| 1.4.2.4.3.530 |  | Construction of box culvertB | 36.25d | 2012-09-06 | 2012-10-10 | 1.4.2.4.3.520 | 72.75d | 10.25d | SSH-Construction Manhours [8500 h] | 37,500 |

| ID | WBS | Activity | Duration | Start | Finish | Predecessors | Total float | Free float | Resources | Cost | QTY |
| --- | --- | --- | --- | --- | --- | --- | --- | --- | --- | --- | --- |
|  | 8 | **Strom Drainage Ponds -A3-5** |  | 2012-06-07 | 2012-10-02 |  |  |  |  |  |  |
| 1.4.2.4.3.610 |  | Excavation for storm water drainage ditchA | 7.5d | 2012-06-07 | 2012-06-14 | 1.4.2.4.3.410 SS | 81.5d | 0d | SSH-Construction Manhours [4200 h]; Excavator [60 h]; Dump Truck [60 h] | 42,862 |  |
| 1.4.2.4.3.620 |  | Leveling -compaction of drainage ditchA | 7.5d | 2012-06-14 | 2012-06-21 | 1.4.2.4.3.610 | 81.5d | 0d | SSH-Construction Manhours [4000 h] | 21,273 |  |
| 1.4.2.4.3.630 |  | Construction of concrete drainage ditchA | 18.75d | 2012-06-21 | 2012-07-09 | 1.4.2.4.3.620 | 81.5d | 0d | SSH-Construction Manhours [16000 h] | 74,405 |  |
| 1.4.2.4.3.640 |  | Excavation for storm water drainage ditchB | 7.5d | 2012-07-09 | 2012-07-16 | 1.4.2.4.3.630 | 81.5d | 0d | SSH-Construction Manhours [3200 h] | 42,863 |  |
| 1.4.2.4.3.650 |  | Leveling -compaction of drainage ditchB | 7.5d | 2012-07-16 | 2012-07-23 | 1.4.2.4.3.640 | 81.5d | 0d | SSH-Construction Manhours [4000 h] | 21,274 |  |
| 1.4.2.4.3.660 |  | Construction of concrete drainage ditchB | 18.75d | 2012-07-23 | 2012-08-09 | 1.4.2.4.3.650 | 81.5d | 0d | SSH-Construction Manhours [16000 h] | 74,406 |  |
| 1.4.2.4.3.670 |  | Excavation for Box culvert A | 7.5d | 2012-08-09 | 2012-08-16 | 1.4.2.4.3.660 | 81.5d | 0d | SSH-Construction Manhours [2400 h] | 22,500 |  |
| 1.4.2.4.3.680 |  | Leveling -compaction of box culvertA | 7.5d | 2012-08-16 | 2012-08-23 | 1.4.2.4.3.670 | 292.75d | 0d | SSH-Construction Manhours [2400 h] | 15,000 |  |
| 1.4.2.4.3.700 |  | Excavation for Box culvert B | 7.5d | 2012-08-16 | 2012-08-23 | 1.4.2.4.3.670 | 81.5d | 0d | SSH-Construction Manhours [2400 h] | 22,500 |  |
| 1.4.2.4.3.690 |  | Construction of box culvertA | 38.75d | 2012-08-23 | 2012-09-29 | 1.4.2.4.3.680 | 292.75d |  | SSH-Construction Manhours [8500 h] | 37,500 |  |
| 1.4.2.4.3.710 |  | Leveling -compaction of box culvertB | 7.5d | 2012-08-23 | 2012-08-30 | 1.4.2.4.3.700 | 81.5d | 0d | SSH-Construction Manhours [2400 h] | 15,000 |  |
| 1.4.2.4.3.720 |  | Construction of box culvertB | 35d | 2012-08-30 | 2012-10-02 | 1.4.2.4.3.710 | 81.5d | 19d | SSH-Construction Manhours [8500 h] | 37,500 |  |
|  | 4 | **Zone 4** |  | 2012-06-10 | 2012-10-03 |  |  |  |  |  |  |
|  | 1 | **Storm Drainage Ditches** |  | 2012-06-10 | 2012-08-29 |  |  |  |  |  |  |
| 1.4.2.4.4.110A |  | Excavation for storm water drainage ditch-A(1200LM) | 10d | 2012-06-10 | 2012-06-18 | 1.4.2.4.1.010 FS+37.5d | 80d | 0d | SSH-Construction Manhours [4000 h] | 10,500 |  |
| 1.4.2.4.4.110B |  | Leveling -compaction of drainage ditch-A | 12.5d | 2012-06-19 | 2012-06-30 | 1.4.2.4.4.110A | 117.5d | 0d | SSH-Construction Manhours [15000 h] | 14,000 |  |
| 1.4.2.4.4.110C |  | Construction of concrete drainage ditch-A | 25d | 2012-07-01 | 2012-07-23 | 1.4.2.4.4.110B | 117.5d | 0d | SSH-Construction Manhours [14000 h] | 180,250 |  |
| 1.4.2.4.4.120A |  | Excavation for storm water drainage ditch-B(1200LM) | 10d | 2012-07-24 | 2012-08-01 | 1.4.2.4.4.110C | 117.5d | 0d | SSH-Construction Manhours [4000 h] | 10,500 |  |
| 1.4.2.4.4.120B |  | Leveling -compaction of drainage ditch-B | 12.5d | 2012-08-02 | 2012-08-13 | 1.4.2.4.4.120A | 117.5d | 0d | SSH-Construction Manhours [5000 h] | 14,000 | 0.0082711084 |
| 1.4.2.4.4.120C |  | Construction of concrete drainage ditch-B | 17.5d | 2012-08-14 | 2012-08-29 | 1.4.2.4.4.120B | 117.5d | 55d | SSH-Construction Manhours [8400 h] | 180,250 |  |
|  | 2 | **Storm Drainage Ponds** |  | 2012-06-14 | 2012-10-03 |  |  |  |  |  |  |
| 1.4.2.4.4.010 |  | Excavation for storm water drainage pond(1) | 7.5d | 2012-06-14 | 2012-06-20 | 1.4.2.4.4.110A SS+5d | 80d | 0d | SSH-Construction Manhours [4200 h] | 160,000 |  |
| 1.4.2.4.4.015 |  | Leveling - compactionfor drainage pond | 15d | 2012-06-21 | 2012-07-04 | 1.4.2.4.4.010 | 80d | 0d | SSH-Construction Manhours [24000 h] | 53,500 |  |
| 1.4.2.4.4.020 |  | Construction of RC spillways | 25d | 2012-07-05 | 2012-07-28 | 1.4.2.4.4.015 | 80d | 0d | SSH-Construction Manhours [21568.1 h] | 84,444 |  |
| 1.4.2.4.4.040 |  | Marl caping for drainage pond | 12.5d | 2012-07-29 | 2012-08-08 | 1.4.2.4.4.110B SS, 1.4.2.4.4.020 | 80d | 0d | SSH-Construction Manhours [10000 h] | 105,000 | 0.0177238036 |
| 1.4.2.4.4.050 |  | Excavation for storm water drainage pond(2) | 7.5d | 2012-08-09 | 2012-08-15 | 1.4.2.4.4.040 | 80d | 0d | SSH-Construction Manhours [2400 h] | 160,000 |  |
| 1.4.2.4.4.060 |  | Leveling - compactionfor drainage pond | 15d | 2012-08-16 | 2012-08-29 | 1.4.2.4.4.050 | 80d | 0d | SSH-Construction Manhours [2400 h] | 53,500 |  |
| 1.4.2.4.4.070 |  | Construction of RC spillways | 25d | 2012-08-30 | 2012-09-22 | 1.4.2.4.4.060 | 80d | 0d | SSH-Construction Manhours [8500 h] | 84,445 |  |
| 1.4.2.4.4.080 |  | Marl caping for drainage pond | 12.5d | 2012-09-23 | 2012-10-03 | 1.4.2.4.4.070 | 80d | 17.5d | SSH-Construction Manhours [2400 h] | 105,000 |  |

| ID | WBS | Activity | Duration | Start | Finish | Predecessors | Total float | Free float | Resources | Cost | QTY |
| --- | --- | --- | --- | --- | --- | --- | --- | --- | --- | --- | --- |
|  | 6 | **Road Networks** |  | 2011-03-19 | 2012-12-17 |  |  |  |  |  |  |
|  | 1 | **Fencing System & Gates** |  | 2011-03-19 | 2011-07-23 |  |  |  |  |  |  |
| 1.4.1.3.1.010 |  | Install temp gate & jersey barriers for zone1 | 23.75d | 2011-03-19 | 2011-04-09 | 1.3.1.5.030 SS, 1.4.1.1.160, 1.3.1.5.130, 1.3.1.6.120 SS | 37.5d | 0d | SSH-Construction Manhours [57000 h]; Crane [190 h]; Trailer [190 h]; Fork-Lifter [190 h] | 340,000 |  |
| 1.4.1.3.3.010 |  | Install temp gate & jersey barriers for zone3 | 65d | 2011-04-10 | 2011-06-08 | 1.4.1.3.1.010 | 37.5d | 0d | SSH-Construction Manhours [312000 h]; Crane [520 h]; Trailer [520 h]; Fork-Lifter [520 h] | 720,000 |  |
| 1.4.1.3.2.010 |  | Install temp gate & jersey barriers for zone2 | 62.5d | 2011-05-26 | 2011-07-23 | 1.4.1.3.3.010 SS+50d | 50d | 0d | SSH-Construction Manhours [360000 h]; Crane [600 h]; Trailer [600 h]; Fork-Lifter [600 h] | 850,000 |  |
| 1.4.1.3.4.010 |  | Install temp gate & jersey barriers for zone4 | 43.75d | 2011-06-13 | 2011-07-23 | 1.4.1.3.2.010 SS+18.75d | 93.75d | 0d | SSH-Construction Manhours [157500 h]; Crane [300 h]; Trailer [300 h]; Fork-Lifter [300 h] | 370,000 | 0.109296789 |
|  | 2 | **Patrol Road works** |  | 2011-07-06 | 2011-10-18 |  |  |  |  |  |  |
| 1.4.2.5.2.010 |  | Install 200mm thk compacted Patrol Roads for Zone 1 | 31.25d | 2011-07-06 | 2011-08-03 | 1.4.1.3.1.010 FS+93.75d | 112.5d | 11d | SSH-Construction Manhours [125000 h]; Grader [250 h]; Compactor [250 h] | 92,500 |  |
| 1.4.2.5.2.030 |  | Install 200mm thk compacted Patrol Roads for Zone 3 | 56.25d | 2011-07-14 | 2011-09-04 | 1.4.1.3.3.010 FS+37.5d | 122.5d | 0d | SSH-Construction Manhours [315000 h]; Grader [450 h]; Compactor [450 h] | 600,000 |  |
| 1.4.2.5.2.020 |  | Install 200mm thk compacted Patrol Roads for Zone 2 | 56.25d | 2011-08-28 | 2011-10-18 | 1.4.1.3.2.010 FS+37.5d | 50d | 0d | SSH-Construction Manhours [247500 h]; Grader [450 h]; Compactor [450 h] | 500,000 |  |
| 1.4.2.5.2.040 |  | Install 200mm thk compacted Patrol Roads for Zone 4 | 25d | 2011-09-14 | 2011-10-06 | 1.4.1.3.4.010 FS+56.25d | 93.75d | 43.75d | SSH-Construction Manhours [60000 h]; Grader [200 h]; Compactor [200 h] | 110,000 | 0.02135098 |
|  | 3 | **Asphalt Road Works A/B/C/D** |  | 2012-04-05 | 2012-12-17 |  |  |  |  |  |  |
| 1.4.2.5.3.010 |  | Site grading/clearing/grubbing | 37.5d | 2012-04-05 | 2012-05-09 | 1.4.2.7.3.050 SS, 1.3.1.1.230 | 0d |  | SSH-Construction Manhours [45000 h]; Grader [600 h]; Dump Truck [600 h] | 170,000 |  |
| 1.4.2.5.3.020 |  | Cut/fill of existing grade | 56.25d | 2012-04-29 | 2012-06-19 | 1.4.2.5.3.010 SS+25d | 75d |  | SSH-Construction Manhours [45000 h]; Grader [600 h]; Dump Truck [600 h] | 460,536 | 0.1360408271 |
| 1.4.2.5.3.040 |  | Laying of geogrid | 75d | 2012-04-29 | 2012-07-07 | 1.4.2.5.3.010 SS+25d, 1.3.1.1.230 | 0d |  | SSH-Construction Manhours [60000 h] | 115,125 |  |
| 1.4.2.5.3.050 |  | backfill with aggregate crushed stone | 75d | 2012-06-03 | 2012-08-11 | 1.4.2.5.3.040 SS+37.5d | 0d |  | SSH-Construction Manhours [60000 h]; Dump Truck [600 h]; Grader [600 h]; Compactor [600 h] | 921,000 |  |
| 1.4.2.5.3.060 |  | Supp & laying of Alyaf geotextile | 75d | 2012-07-08 | 2012-09-15 | 1.4.2.5.3.050 SS+37.5d | 0d |  | SSH-Construction Manhours [60000 h] | 92,100 |  |
| 1.4.2.5.3.070 |  | Supp & lay aggregate base course typeA | 75d | 2012-08-06 | 2012-10-14 | 1.4.2.5.3.060 SS+31.25d, 1.4.2.7.2.090 SS, 1.4.2.5.3.020 SS+31.25d, 1.3.1.6.160 | 0d |  | SSH-Construction Manhours [60000 h]; Grader [600 h]; Dump Truck [600 h]; Compactor [600 h] | 458,928 |  |
| 1.4.2.5.3.080 |  | Install MC70 asphalt prime coat | 75d | 2012-09-04 | 2012-11-12 | 1.4.2.5.3.070 SS+31.25d | 0d |  | SSH-Construction Manhours [120000 h]; Asphalt Machine [600 h] | 50,568 |  |
| 1.4.2.5.3.090 |  | Install asphalt concret binder class A | 75d | 2012-09-04 | 2012-11-12 | 1.4.2.5.3.080 SS | 0d |  | SSH-Construction Manhours [120000 h]; Asphalt Machine [600 h] | 175,080 |  |
| 1.4.2.5.3.100 |  | Install RC 250 asphalt tack coat | 56.25d | 2012-10-03 | 2012-11-24 | 1.4.2.5.3.090 SS+31.25d | 0d |  | SSH-Construction Manhours [90000 h]; Asphalt Machine [450 h] | 50,568 |  |
| 1.4.2.5.3.110 |  | Install asphalt concrt wear course class B | 50d | 2012-11-01 | 2012-12-17 | 1.4.2.5.3.100 SS+31.25d | 0d |  | SSH-Construction Manhours [80000 h]; Asphalt Machine [400 h] | 102,840 |  |
|  | 4 | **Curbs & Walkways** |  | 2012-05-10 | 2012-12-11 |  |  |  |  |  |  |
| 1.4.2.5.4.010 |  | Install curb & gutter & walkways Zone3 - A3-1 | 56.25d | 2012-05-10 | 2012-07-01 | 1.4.2.5.3.010 SS+37.5d, 1.3.1.2.060 | 6.25d | 0d | SSH-Construction Manhours [22500 h] | 130,000 |  |
| 1.4.2.5.4.020 |  | Install curb & gutter & walkways Zone3 - A3-2 | 50d | 2012-07-02 | 2012-08-16 | 1.4.2.5.4.010 | 6.25d | 0d | SSH-Construction Manhours [20000 h] | 130,000 |  |
| 1.4.2.5.4.030 |  | Install curb & gutter & walkways Zone3 - A3-3 | 56.25d | 2012-08-18 | 2012-10-08 | 1.4.2.5.4.020 | 6.25d | 0d | SSH-Construction Manhours [22500 h] | 130,000 |  |
| 1.4.2.5.4.040 |  | Install curb & gutter & walkways Zone2 - A2-1 | 31.25d | 2012-10-09 | 2012-11-06 | 1.4.2.5.4.030 | 6.25d | 0d | SSH-Construction Manhours [15000 h] | 130,000 |  |
| 1.4.2.5.4.050 |  | Install curb & gutter & walkways Zone2 - A2-2 | 37.5d | 2012-11-07 | 2012-12-11 | 1.4.2.5.4.040 | 6.25d |  | SSH-Construction Manhours [75000 h] | 130,000 |  |

| ID | WBS | Activity | Duration | Start | Finish | Predecessors | Total float | Free float | Resources | Cost |
| --- | --- | --- | --- | --- | --- | --- | --- | --- | --- | --- |
|  | 5 | **Segway / Bicycle lane** |  | 2012-05-20 | 2012-12-05 |  |  |  |  |  |
| 1.4.2.5.5.010A |  | Site grading/sub-grade course compaction Zone3 -A3-1 | 18.75d | 2012-05-20 | 2012-06-05 | 1.4.2.5.4.010 SS+10d | 105d | 0d | SSH-Construction Manhours [15000 h]; Dump Truck [150 h]; Grader [150 h] | 9,180 |
| 1.4.2.5.5.010B |  | Install agregate grade course type A Zone3 - A3-1 | 12.5d | 2012-06-06 | 2012-06-17 | 1.4.2.5.5.010A | 105d | 0d | SSH-Construction Manhours [6000 h]; Asphalt Machine [100 h] | 20,152 |
| 1.4.2.5.5.010C |  | Install RC pavement for bicycle lane Zone3 - A3-1 | 12.5d | 2012-06-18 | 2012-06-28 | 1.4.2.5.5.010B | 105d | 0d | SSH-Construction Manhours [7000 h]; Asphalt Machine [100 h] | 192,360 |
| 1.4.2.5.5.020A |  | Site grading/sub-grade course compaction Zone3 -A3-2 | 18.75d | 2012-06-30 | 2012-07-16 | 1.4.2.5.5.010C | 105d | 0d | SSH-Construction Manhours [6000 h]; Grader [150 h]; Dump Truck [150 h] | 9,180 |
| 1.4.2.5.5.020B |  | Install agregate grade course type A Zone3 - A3-2 | 12.5d | 2012-07-17 | 2012-07-28 | 1.4.2.5.5.020A | 105d | 0d | SSH-Construction Manhours [4000 h]; Asphalt Machine [100 h] | 20,152 |
| 1.4.2.5.5.020C |  | Install RC pavement for bicycle lane Zone3 - A3-2 | 12.5d | 2012-07-29 | 2012-08-08 | 1.4.2.5.5.020B | 105d | 0d | SSH-Construction Manhours [5000 h]; Asphalt Machine [100 h] | 192,360 |
| 1.4.2.5.5.030A |  | Site grading/sub-grade course compaction Zone3 -A3-3 | 27.5d | 2012-08-09 | 2012-09-03 | 1.4.2.5.5.020C | 105d | 0d | SSH-Construction Manhours [8800 h]; Dump Truck [220 h]; Grader [220 h] | 9,180 |
| 1.4.2.5.5.030B |  | Install agregate grade course type A Zone3 - A3-3 | 17.5d | 2012-09-04 | 2012-09-19 | 1.4.2.5.5.030A | 105d | 0d | SSH-Construction Manhours [5600 h]; Asphalt Machine [140 h] | 20,152 |
| 1.4.2.5.5.030C |  | Install RC pavement for bicycle lane Zone3 - A3-3 | 17.5d | 2012-09-20 | 2012-10-06 | 1.4.2.5.5.030B | 105d | 0d | SSH-Construction Manhours [7000 h]; Asphalt Machine [140 h] | 192,360 |
| 1.4.2.5.5.040A |  | Site grading/sub-grade course compaction Zone2 -A2-1 | 10d | 2012-10-07 | 2012-10-15 | 1.4.2.5.5.030C | 105d | 0d | SSH-Construction Manhours [3200 h]; Dump Truck [80 h]; Trailer [80 h] | 9,180 |
| 1.4.2.5.5.040B |  | Install agregate grade course type A Zone2 - A2-1 | 7.5d | 2012-10-16 | 2012-10-22 | 1.4.2.5.5.040A | 105d | 0d | SSH-Construction Manhours [3000 h]; Asphalt Machine [60 h] | 20,152 |
| 1.4.2.5.5.040C |  | Install RC pavement for bicycle lane Zone2 - A2-1 | 7.5d | 2012-10-23 | 2012-10-29 | 1.4.2.5.5.040B | 105d | 0d | SSH-Construction Manhours [3000 h]; Asphalt Machine [60 h] | 192,360 |
| 1.4.2.5.5.050A |  | Site grading/sub-grade course compaction Zone2 -A2-2 | 15d | 2012-10-30 | 2012-11-12 | 1.4.2.5.5.040C | 105d | 0d | SSH-Construction Manhours [18000 h]; Grader [120 h]; Dump Truck [120 h] | 9,180 |
| 1.4.2.5.5.050B |  | Install agregate grade course type A Zone2 - A2-2 | 12.5d | 2012-11-13 | 2012-11-24 | 1.4.2.5.5.050A | 105d | 0d | SSH-Construction Manhours [15000 h]; Asphalt Machine [100 h] | 20,152 |
| 1.4.2.5.5.050C |  | Install RC pavement for bicycle lane Zone2 - A2-2 | 12.5d | 2012-11-25 | 2012-12-05 | 1.4.2.5.5.050B | 105d | 25d | SSH-Construction Manhours [15000 h]; Asphalt Machine [100 h] | 192,360 |
|  | 6 | **Traffic Signage** |  | 2012-09-04 | 2012-12-11 |  |  |  |  |  |
| 1.4.2.5.6.010A |  | Install road markings Zone 3 - A3-1 | 18.75d | 2012-09-04 | 2012-09-20 | 1.4.2.5.3.090 SS, 1.3.1.6.180 | 6.25d | 0d | SSH-Construction Manhours [12000 h] | 33,074 |
| 1.4.2.5.6.010B |  | Install road markings Zone 3 - A3-2 | 25d | 2012-09-22 | 2012-10-14 | 1.4.2.5.6.010A | 12.5d | 0d | SSH-Construction Manhours [16000 h] | 33,073 |
| 1.4.2.5.6.020A |  | Install road signage with GI pipe post Zone3 - A3-1 | 22.5d | 2012-09-22 | 2012-10-11 | 1.4.2.5.6.010A | 6.25d | 0d | SSH-Construction Manhours [18000 h] | 8,000 |
| 1.4.2.5.6.020B |  | Install road signage with GI pipe post Zone3 - A3-2 | 25d | 2012-10-13 | 2012-11-04 | 1.4.2.5.6.020A | 6.25d | 0d | SSH-Construction Manhours [12000 h] | 8,000 |
| 1.4.2.5.6.010C |  | Install road markings Zone 3 - A3-3 | 31.25d | 2012-10-15 | 2012-11-12 | 1.4.2.5.6.010B | 12.5d | 0d | SSH-Construction Manhours [20000 h] | 33,073 |
| 1.4.2.5.6.020C |  | Install road signage with GI pipe post Zone3 - A3-3 | 31.25d | 2012-11-05 | 2012-12-03 | 1.4.2.5.6.020B | 6.25d | 0d | SSH-Construction Manhours [37500 h] | 8,000 |
| 1.4.2.5.6.010D |  | Install road markings Zone 2 | 25d | 2012-11-13 | 2012-12-05 | 1.4.2.5.6.010C | 12.5d |  | SSH-Construction Manhours [70000 h] | 33,075 |
| 1.4.2.5.6.020D |  | Install road signage with GI pipe post Zone2 | 18.75d | 2012-11-25 | 2012-12-11 | 1.4.2.5.6.020C SS+21.25d | 6.25d |  | SSH-Construction Manhours [60000 h] | 6,000 |

| ID | WBS | Activity | Duration | Start | Finish | Predecessors | Total float | Free float | Resources | Cost | QTY |
| --- | --- | --- | --- | --- | --- | --- | --- | --- | --- | --- | --- |
|  | 7 | **Landscaping & Hardscaping** |  | 2012-04-05 | 2012-12-08 |  |  |  |  |  |  |
|  | 1 | **Landscaping & Hardscaping** |  | 2012-04-05 | 2012-12-08 |  |  |  |  |  |  |
|  | 1 | **Zone 3** |  | 2012-04-05 | 2012-12-08 |  |  |  |  |  |  |
| 1.4.2.6.010 |  | Site grading/clearing/grubbing | 75d | 2012-04-05 | 2012-06-13 | 1.4.2.5.3.010 SS, 1.3.4.1.030 | 10d | 0d | SSH-Construction Manhours [30000 h]; Grader [600 h]; Dump Truck [600 h] | 39,000 |  |
| 1.4.2.6.020 |  | Cut/fill upto exisitng grade | 75d | 2012-04-23 | 2012-07-01 | 1.4.2.6.010 SS+18.75d | 68.75d | 0d | SSH-Construction Manhours [30000 h]; Grader [600 h]; Dump Truck [600 h] | 61,625 |  |
| 1.4.2.6.130 |  | constrcution (structural/archt'l) of water fountain | 75d | 2012-04-23 | 2012-07-01 | 1.4.2.6.010 SS+7.5d, 1.4.2.6.020 SS | 68.75d | 0d | SSH-Construction Manhours [30000 h] | 250,000 |  |
| 1.4.2.6.030 |  | Fill/compaction upto lower level | 75d | 2012-04-29 | 2012-07-07 | 1.4.2.6.010 SS+25d | 10d | 0d | SSH-Construction Manhours [30000 h] | 922,600 |  |
| 1.4.2.6.040 |  | Aggregarte basecoarse for sidewalk & walkways | 75d | 2012-05-16 | 2012-07-24 | 1.4.2.6.030 SS+18.75d | 10d | 0d | SSH-Construction Manhours [36000 h] | 168,641 |  |
| 1.4.2.6.140 |  | constrcution (structural/archt'l) of fitness park | 75d | 2012-05-28 | 2012-08-05 | 1.4.2.6.130 SS+37.5d | 68.75d | 58.75d | SSH-Construction Manhours [42000 h] | 270,000 |  |
| 1.4.2.6.050 |  | Sweet sand basecoarse for sidewalk & walkways | 75d | 2012-06-03 | 2012-08-11 | 1.4.2.6.040 SS+18.75d, 1.3.5.3.3.030, 1.3.5.3.4.030 | 10d | 0d | SSH-Construction Manhours [60000 h] | 78,188 |  |
| 1.4.2.6.060 |  | RC pavement for walkways | 75d | 2012-06-20 | 2012-08-28 | 1.4.2.6.050 SS+18.75d | 10d | 0d | SSH-Construction Manhours [60000 h] | 690,000 |  |
| 1.4.2.6.070 |  | Interlocking tiles for walkways | 75d | 2012-06-27 | 2012-09-04 | 1.4.2.6.060 SS+7.5d | 10d | 0d | SSH-Construction Manhours [48000 h] | 570,736 |  |
| 1.4.2.6.080 |  | Decorative interlocking tiles for wlaslkways | 75d | 2012-07-15 | 2012-09-22 | 1.4.2.6.070 SS+18.75d | 10d | 0d | SSH-Construction Manhours [48000 h] | 550,000 |  |
| 1.4.2.6.090 |  | concrete edging for walkways | 112.5d | 2012-08-01 | 2012-11-13 | 1.4.2.6.080 SS+18.75d | 10d | 0d | SSH-Construction Manhours [45000 h] | 497,250 |  |
| 1.4.2.6.100 |  | sweet sand for playground area | 75d | 2012-08-08 | 2012-10-16 | 1.4.2.6.090 SS+7.5d | 10d | 0d | SSH-Construction Manhours [30000 h] | 205,800 |  |
| 1.4.2.6.150 |  | constrcution (structural/archt'l) of play park fountain & fitting | 75d | 2012-08-08 | 2012-10-16 | 1.4.2.6.100 SS, 1.4.2.6.140 SS+18.75d, 1.3.4.1.130 | 10d | 0d | SSH-Construction Manhours [36000 h] | 200,000 |  |
| 1.4.2.6.110 |  | gravel mulch for trees well | 75d | 2012-08-26 | 2012-11-03 | 1.4.2.6.100 SS+18.75d | 32.5d | 0d | SSH-Construction Manhours [30000 h] | 1,596,160 |  |
| 1.4.2.6.120 |  | natural stone boulder/sculptured(1each large & 2 small) | 71.25d | 2012-09-12 | 2012-11-17 | 1.4.2.6.110 SS+18.75d | 32.5d |  | SSH-Construction Manhours [57000 h] | 850,000 |  |
| 1.4.2.6.160 |  | Install Maze & Labyrinth | 37.5d | 2012-09-30 | 2012-11-03 | 1.4.2.6.150 SS+56.25d, 1.4.2.7.3.040 | 10d | 0d | SSH-Construction Manhours [18000 h] | 250,000 |  |
| 1.4.2.6.170 |  | Install Turfin & ground cover | 37.5d | 2012-11-04 | 2012-12-08 | 1.4.2.6.160 | 10d |  | SSH-Construction Manhours [45000 h] | 600,000 |  |
|  | 8 | **Power Distribution** |  | 2011-08-14 | 2012-10-13 |  |  |  |  |  |  |
|  | 01 | **MV Cables** |  | 2011-12-06 | 2012-05-17 |  |  |  |  |  |  |
| 1.4.2.7.1.010 |  | Excavation of trench for MV cables & Ductbanks | 31.25d | 2011-12-06 | 2012-01-04 | 1.3.2.7.8.030, 1.3.2.3.030, Z3.2180 SS, 1.3.3.2.8.030 | 37.75d | 0d | SSH-Construction Manhours [17500 h]; Excavator [250 h]; Dump Truck [250 h] | 42,625 |  |
| 1.4.2.7.1.060 |  | Splic/hi-pot/termintaion of MV cables | 25d | 2012-02-26 | 2012-03-20 | 1.4.2.7.510 | 37.75d | 0d | SSH-Construction Manhours [12000.7 h] | 250,000 |  |
| 1.4.2.7.1.070 |  | Testing & Pre-commissioning of MV cables | 25d | 2012-03-20 | 2012-04-12 | 1.4.2.7.1.060, 1.4.2.7.1.130, 1.4.2.7.230, 1.4.2.7.330, 1.4.2.7.510 | 37.75d | 0d | SSH-Construction Manhours [10000 h] | 100,000 |  |
| 1.4.2.7.1.050 |  | Install red tiles/cable markers | 37.5d | 2012-04-12 | 2012-05-17 | 1.4.2.7.1.070, 1.4.2.7.510 | 42.75d | 0d | SSH-Construction Manhours [24000 h] | 225,000 |  |
| 1.4.2.7.1.080 |  | Backfilling of MV cables | 37.5d | 2012-04-12 | 2012-05-17 | 1.4.2.7.1.050 SS | 42.75d | 5d | SSH-Construction Manhours [18000 h]; Dump Truck [300 h] | 205,000 | 0.060556329 |

| ID | WBS | Activity | Duration | Start | Finish | Predecessors | Total float | Free float | Resources | Cost | QTY |
| --- | --- | --- | --- | --- | --- | --- | --- | --- | --- | --- | --- |
|  | 1 | **Zone 3 - A3-1 & 4** |  | 2011-12-06 | 2012-01-19 |  |  |  |  |  |  |
| 1.4.2.7.1.100 |  | Excavation of MV cable trench | 10d | 2011-12-06 | 2011-12-15 | 1.4.2.7.1.010 SS | 102.75d | 0d | SSH-Construction Manhours [3000 h]; Excavator [80 h]; Dump Truck [80 h] | 42,625 |  |
| 1.4.2.7.1.110 |  | Install MV cable A | 12.5d | 2011-12-15 | 2011-12-27 | 1.4.2.7.1.010 SS, 1.4.2.7.1.100 | 102.75d | 0d | SSH-Construction Manhours [15000 h]; Cable Puller [100 h] | 249,155 |  |
| 1.4.2.7.1.120 |  | Install MV cable B | 12.5d | 2011-12-27 | 2012-01-08 | 1.4.2.7.1.110 | 102.75d | 0d | SSH-Construction Manhours [15000 h]; Cable Puller [100 h] | 249,155 |  |
| 1.4.2.7.1.130 |  | Install MV cable C | 12.5d | 2012-01-08 | 2012-01-19 | 1.4.2.7.1.120 | 102.75d | 65d | SSH-Construction Manhours [15000 h]; Cable Puller [100 h] | 249,155 |  |
|  | 2 | **Zone 3 - A3-2** |  | 2011-12-15 | 2012-01-29 |  |  |  |  |  |  |
| 1.4.2.7.200 |  | Excavation of MV cable trench | 10d | 2011-12-15 | 2011-12-25 | 1.4.2.7.1.010 SS+10d | 92.75d | 0d | SSH-Construction Manhours [3000 h]; Excavator [80 h]; Dump Truck [80 h] | 42,625 |  |
| 1.4.2.7.210 |  | Install MV cable A | 12.5d | 2011-12-25 | 2012-01-05 | 1.4.2.7.1.010 SS, 1.4.2.7.200 | 92.75d | 0d | SSH-Construction Manhours [15000 h]; Cable Puller [100 h] | 249,155 |  |
| 1.4.2.7.220 |  | Install MV cable B | 12.5d | 2012-01-05 | 2012-01-17 | 1.4.2.7.210 | 92.75d | 0d | SSH-Construction Manhours [15000 h]; Cable Puller [100 h] | 249,155 |  |
| 1.4.2.7.230 |  | Install MV cable C | 12.5d | 2012-01-17 | 2012-01-29 | 1.4.2.7.220 | 92.75d | 55d | SSH-Construction Manhours [15000 h]; Cable Puller [100 h] | 249,155 |  |
|  | 3 | **Zone 3 - A3-3** |  | 2011-12-18 | 2012-01-31 |  |  |  |  |  |  |
| 1.4.2.7.300 |  | Excavation of MV cable trench | 10d | 2011-12-18 | 2011-12-27 | 1.4.2.7.1.010 SS+12.5d | 90.25d | 0d | SSH-Construction Manhours [3000 h]; Excavator [80 h]; Dump Truck [80 h] | 42,625 |  |
| 1.4.2.7.310 |  | Install MV cable A | 12.5d | 2011-12-27 | 2012-01-08 | 1.4.2.7.1.010 SS, 1.4.2.7.300 | 90.25d | 0d | SSH-Construction Manhours [15000 h]; Cable Puller [100 h] | 249,155 |  |
| 1.4.2.7.320 |  | Install MV cable B | 12.5d | 2012-01-08 | 2012-01-19 | 1.4.2.7.310 | 90.25d | 0d | SSH-Construction Manhours [15000 h]; Cable Puller [100 h] | 249,155 |  |
| 1.4.2.7.330 |  | Install MV cable C | 12.5d | 2012-01-19 | 2012-01-31 | 1.4.2.7.320 | 90.25d | 52.5d | SSH-Construction Manhours [15000 h]; Cable Puller [100 h] | 249,155 |  |
|  | 4 | **Zone 3 - A3-4** |  | 2011-12-20 | 2012-01-08 |  |  |  |  |  |  |
| 1.4.2.7.400 |  | Excavation of MV cable trench | 5d | 2011-12-20 | 2011-12-25 | 1.4.2.7.1.010 SS+15d | 82.75d | 0d | SSH-Construction Manhours [3000 h]; Excavator [40 h]; Dump Truck [40 h] | 42,625 |  |
| 1.4.2.7.410 |  | Install MV cable A | 7.5d | 2011-12-25 | 2012-01-01 | 1.4.2.7.1.010 SS, 1.4.2.7.400 | 82.75d | 0d | SSH-Construction Manhours [25000 h]; Cable Puller [60 h] | 249,155 |  |
| 1.4.2.7.420 |  | Install MV cable B | 7.5d | 2012-01-01 | 2012-01-08 | 1.4.2.7.410 | 82.75d | 45d | SSH-Construction Manhours [25000 h]; Cable Puller [60 h] | 249,155 |  |
|  | 5 | **Zone 3 - A3-5** |  | 2012-02-14 | 2012-02-26 |  |  |  |  |  |  |
| 1.4.2.7.500 |  | Excavation of MV cable trench | 5d | 2012-02-14 | 2012-02-19 | 1.4.2.7.1.010 SS+75d | 37.75d | 0d | SSH-Construction Manhours [2000 h]; Excavator [40 h]; Dump Truck [40 h] | 42,625 |  |
| 1.4.2.7.510 |  | Install MV cable A | 7.5d | 2012-02-19 | 2012-02-26 | 1.4.2.7.420, 1.4.2.7.500 | 37.75d | 0d | SSH-Construction Manhours [15000 h]; Cable Puller [60 h] | 249,164 |  |
|  | 6 | **Zone 2 & 1** |  |  |  |  |  |  |  |  |  |
|  | 02 | **LV Cables - Lighting Power Cables (For Permanent Roads)** |  | 2011-12-18 | 2012-09-20 |  |  |  |  |  |  |
| 1.4.2.7.2.010 |  | Excavation of trench for lighting power cables | 56.25d | 2011-12-18 | 2012-02-08 | 1.4.2.7.1.010 SS+12.5d | 41.5d | 0d | SSH-Construction Manhours [11035.1 h]; Excavator [450 h]; Dump Truck [450 h] | 44,250 |  |
| 1.4.2.7.2.030 |  | Install lighting power cables | 75d | 2012-02-23 | 2012-05-02 | 1.4.2.7.2.010 SS+18.75d, 1.4.5.4.6.030 | 25d | 0d | SSH-Construction Manhours [60000 h]; Cable Puller [600 h] | 750,000 |  |
| 1.4.2.7.2.050 |  | Install red tiles/cable markers for lighting cables | 37.5d | 2012-04-16 | 2012-05-20 | 1.4.2.7.2.030 SS+56.25d | 25d | 0d | SSH-Construction Manhours [12000 h] | 20,550 |  |
| 1.4.2.7.2.070 |  | Testing & commissioning of lighting cables | 37.5d | 2012-05-03 | 2012-06-06 | 1.4.2.7.2.050 SS+18.75d | 25d | 0d | SSH-Construction Manhours [12000 h] | 25,000 |  |
| 1.4.2.7.2.080 |  | Install lighting poles | 75d | 2012-06-07 | 2012-08-15 | 1.4.2.7.2.070, 1.3.5.4.4.030, 1.4.5.4.5.030 | 25d | 0d | SSH-Construction Manhours [50000 h]; Crane [600 h] | 102,600 |  |
| 1.4.2.7.2.090 |  | Install lighting pole fixture | 75d | 2012-07-14 | 2012-09-20 | 1.4.2.7.2.080 SS+38.75d, 1.4.2.5.2.030 SS | 25d | 0d | SSH-Construction Manhours [36000 h] | 409,200 | 0.1208763407 |

| ID | WBS | Activity | Duration | Start | Finish | Predecessors | Total float | Free float | Resources | Cost | QTY |
| --- | --- | --- | --- | --- | --- | --- | --- | --- | --- | --- | --- |
|  | 03 | **LV Cables (For Patrol Roads)** |  | 2011-08-14 | 2011-12-10 |  |  |  |  |  |  |
| 1.4.2.7.2.110 |  | Install LV cables & Lightings in Zone1 | 18.75d | 2011-08-14 | 2011-08-31 | 1.3.5.4.1.030, 1.3.5.4.2.030, 1.3.5.4.3.030, 1.4.2.5.2.010 | 101.5d | 51.5d | SSH-Construction Manhours [60000 h]; Cable Puller [150 h] | 18,186 |  |
| 1.4.2.7.2.150 |  | Install LV cables & Lightings in Zone3 | 31.25d | 2011-09-05 | 2011-10-03 | 1.4.2.5.2.030 | 122.5d | 81d | SSH-Construction Manhours [125000 h]; Cable Puller [250 h] | 8,446 |  |
| 1.4.2.7.2.130 |  | Install LV cables & Lightings in Zone2 | 31.25d | 2011-10-19 | 2011-11-16 | 1.4.2.5.2.020, 1.4.2.7.2.110 | 50d | 0d | SSH-Construction Manhours [125000 h]; Cable Puller [250 h] | 308,235 |  |
| 1.4.2.7.2.170 |  | Install LV cables & Lightings in Zone4 | 25d | 2011-11-17 | 2011-12-10 | 1.4.2.5.2.040, 1.4.2.7.2.130 | 50d | 8.5d | SSH-Construction Manhours [60000 h]; Cable Puller [200 h] | 10,274 |  |
|  | 04 | **Irrigation Cables** |  | 2011-12-18 | 2012-05-29 |  |  |  |  |  |  |
| 1.4.2.7.3.010 |  | Excavation of trench for irrigation cables | 56.25d | 2011-12-18 | 2012-02-08 | 1.4.2.7.2.010 SS, 1.4.2.7.2.150, 1.4.2.7.2.170 | 41.5d | 0d | SSH-Construction Manhours [13500 h]; Excavator [450 h]; Dump Truck [450 h] | 30,000 |  |
| 1.4.2.7.3.030 |  | Install irrigation cables | 62.5d | 2011-12-29 | 2012-02-26 | 1.4.2.7.3.010 SS+12.5d | 41.5d | 0d | SSH-Construction Manhours [36000 h]; Cable Puller [500 h] | 250,000 |  |
| 1.4.2.7.3.050 |  | Testing & commissioning of irrigation cables | 31.25d | 2012-02-26 | 2012-03-26 | 1.4.2.7.3.030 | 41.5d | 0d | SSH-Construction Manhours [28800 h] | 20,000 | 0.0059079345 |
| 1.4.2.7.3.040 |  | Install solar powered irrigation controller | 75d | 2012-03-20 | 2012-05-29 | 1.4.2.7.3.050 SS+25d | 141.5d | 131.5d | SSH-Construction Manhours [72000 h] | 50,700 |  |
|  | 05 | **Electrcial Equipments** |  | 2011-11-23 | 2012-10-13 |  |  |  |  |  |  |
|  | 1 | **Switchgears** |  | 2012-04-17 | 2012-04-28 |  |  |  |  |  |  |
| 1.4.2.7.4.010 |  | Install switchgear SS4 | 7.5d | 2012-04-17 | 2012-04-24 | 1.4.2.7.1.070 FS+5d, 1.4.3.1.1.440 SS, 1.3.2.1.030 | 37.75d | 0d | SSH-Construction Manhours [4800 h] | 400,000 |  |
| 1.4.2.7.4.020 |  | Install switchgear SS5 | 7.5d | 2012-04-17 | 2012-04-24 | 1.4.2.7.1.070, 1.4.2.7.4.010 SS, 1.3.2.1.020, 1.4.2.7.1.080 SS | 37.75d | 0d | SSH-Construction Manhours [4800 h] | 400,000 |  |
| 1.4.2.7.4.015 |  | Testing & commissioning of switchgears | 3.75d | 2012-04-24 | 2012-04-28 | 1.4.2.7.4.010, 1.4.4.4.010 SS+37.5d | 38.25d | 0d | SSH-Construction Manhours [2000 h] | 240,000 |  |
| 1.4.2.7.4.025 |  | Testing & commissioning of switchgears | 3.75d | 2012-04-24 | 2012-04-28 | 1.4.2.7.4.020 | 37.75d | 0d | SSH-Construction Manhours [2000 h] | 240,000 | 0.0708952145 |
|  | 2 | **Package Substations** |  | 2011-11-23 | 2012-05-08 |  |  |  |  |  |  |
| 1.4.2.7.4.030 |  | Construction of package substation foundations | 120d | 2011-11-23 | 2012-03-13 | 1.4.3.1.1.040 | 116.75d | 0d | SSH-Construction Manhours [96000 h] | 247,000 |  |
| 1.4.2.7.4.040 |  | Install package substation SS4 | 7.5d | 2012-04-28 | 2012-05-05 | 1.3.2.2.1.020, 1.4.2.7.4.030 SS+90d, 1.3.2.2.1.030, 1.4.2.7.4.015 | 38.25d | 0d | SSH-Construction Manhours [4800 h] | 137,500 |  |
| 1.4.2.7.4.050 |  | Install package substation SS5 | 7.5d | 2012-04-28 | 2012-05-05 | 1.4.2.7.4.020 SS+5d, 1.3.2.2.1.020, 1.4.2.7.4.025 | 37.75d | 0d | SSH-Construction Manhours [4800 h] | 137,500 |  |
| 1.4.2.7.4.045 |  | Testing & commissioning of package substations | 3.75d | 2012-05-05 | 2012-05-08 | 1.4.2.7.4.040 SS+7d | 38.25d | 0d | SSH-Construction Manhours [2000 h] | 110,000 |  |
| 1.4.2.7.4.055 |  | Testing & commissioning of package substations | 3.75d | 2012-05-05 | 2012-05-08 | 1.4.2.7.4.050 | 37.75d | 0d | SSH-Construction Manhours [2000 h] | 110,000 | 0.03249364 |
|  | 3 | **RMU** |  | 2011-11-23 | 2012-09-12 |  |  |  |  |  |  |
| 1.4.2.7.4.060 |  | Constrcution of RMU foundations | 150d | 2011-11-23 | 2012-04-10 | 1.4.2.7.4.030 SS | 122.5d | 0d | SSH-Construction Manhours [120000 h] | 969,000 |  |
| 1.4.2.7.4.070 |  | Install RMU-SS4 | 18.75d | 2012-05-08 | 2012-05-26 | 1.4.2.7.4.040 SS, 1.3.2.2.2.020, 1.4.2.7.4.060 SS+60d, 1.3.2.2.2.030, 1.4.2.7.4.045 | 38.25d | 0d | SSH-Construction Manhours [10500 h] | 1,200,000 |  |
| 1.4.2.7.4.072 |  | Install RMU-SS5 | 18.75d | 2012-05-08 | 2012-05-26 | 1.4.2.7.4.050 SS, 1.4.2.7.4.070 SS, 1.3.2.2.2.020, 1.4.2.7.4.055 | 37.75d | 0d | SSH-Construction Manhours [10500 h] | 1,200,000 |  |
| 1.4.2.7.4.071 |  | Testing & commissioning of RMU-SS4 | 6.25d | 2012-05-26 | 2012-05-31 | 1.4.2.7.4.070 | 38.25d | 0d | SSH-Construction Manhours [3000 h] | 170,000 |  |
| 1.4.2.7.4.073 |  | Testing & commissioning of RMU-SS5 | 6.25d | 2012-05-26 | 2012-05-31 | 1.4.2.7.4.072 SS+18.75d | 37.75d | 0d | SSH-Construction Manhours [3000 h] | 170,000 |  |
| 1.4.2.7.4.074 |  | Install RMU-road lighting | 90d | 2012-06-07 | 2012-08-29 | 1.4.2.7.2.070 | 195d | 0d | SSH-Construction Manhours [22070.2 h] | 150,000 |  |
| 1.4.2.7.4.075 |  | Testing & commissioning of road lighting RMU | 45d | 2012-08-02 | 2012-09-12 | 1.4.2.7.4.074 SS+60d, 1.4.2.7.4.073 | 195d | 115d | SSH-Construction Manhours [18000 h] | 170,000 | 0.0502174436 |

| ID | WBS | Activity | Duration | Start | Finish | Predecessors | Total float | Free float | Resources | Cost | QTY |
| --- | --- | --- | --- | --- | --- | --- | --- | --- | --- | --- | --- |
|  | 4 | **Generators** |  | 2011-12-21 | 2012-09-09 |  |  |  |  |  |  |
| 1.4.2.7.4.090 |  | Construction of generator foundations | 90d | 2011-12-21 | 2012-03-13 | 1.4.2.7.4.060 SS+30d | 122.5d | 0d | SSH-Construction Manhours [72000 h] | 102,600 |  |
| 1.4.2.7.4.107 |  | Install generator LS9 | 15d | 2012-07-23 | 2012-08-06 | 1.4.2.7.4.176 | 56d | 0d | SSH-Construction Manhours [7200 h] | 50,000 |  |
| 1.4.2.7.4.105 |  | Install generator LS12 | 15d | 2012-08-06 | 2012-08-19 | 1.4.2.7.4.174 SS+7.5d, 1.3.2.5.030 | 35d | 0d | SSH-Construction Manhours [7200 h] | 50,000 |  |
| 1.4.2.7.4.108 |  | Testing & commissioning of generator LS9 | 10d | 2012-08-06 | 2012-08-15 | 1.4.2.7.4.107 | 56d | 7d | SSH-Construction Manhours [2400 h] | 50,000 | 0.0147698364 |
| 1.4.2.7.4.101 |  | Install generator LS10 | 15d | 2012-08-14 | 2012-08-27 | 1.4.2.7.4.090 SS, 1.3.2.5.020, 1.4.2.7.4.170 SS+10d | 37.5d | 0d | SSH-Construction Manhours [7200 h] | 50,000 |  |
| 1.4.2.7.4.106 |  | Testing & commissioning of generator LS12 | 10d | 2012-08-15 | 2012-08-23 | 1.4.2.7.4.105 SS+10d | 35d | 3.75d | SSH-Construction Manhours [2400 h] | 50,000 |  |
| 1.4.2.7.4.103 |  | Install generator LS11 | 15d | 2012-08-22 | 2012-09-04 | 1.4.2.7.4.172 SS | 30d | 0d | SSH-Construction Manhours [7200 h] | 50,000 |  |
| 1.4.2.7.4.102 |  | Testing & commissioning of generator LS10 | 10d | 2012-08-23 | 2012-09-01 | 1.4.2.7.4.101 SS+10d | 37.5d | 0d | SSH-Construction Manhours [3200 h] | 50,000 |  |
| 1.4.2.7.4.104 |  | Testing & commissioning of generator LS11 | 10d | 2012-09-01 | 2012-09-09 | 1.4.2.7.4.103 SS+10d | 30d | 0d | SSH-Construction Manhours [2400 h] | 50,000 |  |
|  | 5 | **Submersible Pumps** |  | 2012-06-27 | 2012-10-13 |  |  |  |  |  |  |
| 1.4.2.7.4.126 |  | Install submersible pumps - LS pumps LS9 | 56.25d | 2012-06-27 | 2012-08-19 | 1.4.2.3.5.150 | 56d | 0d | SSH-Construction Manhours [18000 h] | 45,000 |  |
| 1.4.2.7.4.120 |  | Install submersible pumps - LS pumps LS10 | 56.25d | 2012-07-07 | 2012-08-27 | 1.3.2.4.020, 1.3.5.2.4.020, 1.3.5.2.5.020, 1.4.2.3.6.150 | 37.5d | 0d | SSH-Construction Manhours [13500 h] | 45,000 |  |
| 1.4.2.7.4.122 |  | Install submersible pumps - LS pumps LS11 | 56.25d | 2012-07-07 | 2012-08-27 | 1.4.2.3.7.150, 1.3.2.4.030 | 30d | 0d | SSH-Construction Manhours [13500 h] | 45,000 |  |
| 1.4.2.7.4.124 |  | Install submersible pumps - LS pumps LS12 | 56.25d | 2012-07-30 | 2012-09-19 | 1.4.2.3.8.150 | 35d | 0d | SSH-Construction Manhours [24000 h] | 45,000 |  |
| 1.4.2.7.4.127 |  | Testing & commissioning of LS submersible pumps LS9 | 31.25d | 2012-08-13 | 2012-09-11 | 1.4.2.7.4.126 SS+50d | 72.25d | 42.25d | SSH-Construction Manhours [7500 h] | 5,000 | 0.0014769836 |
| 1.4.2.7.4.121 |  | Testing & commissioning of LS submersible pumps LS10 | 31.25d | 2012-08-22 | 2012-09-19 | 1.4.2.7.4.120 SS+50d | 62.5d | 32.5d | SSH-Construction Manhours [10000 h] | 5,000 |  |
| 1.4.2.7.4.123 |  | Testing & commissioning of LS submersible pumps LS11 | 31.25d | 2012-08-22 | 2012-09-19 | 1.4.2.7.4.122 SS+50d | 62.5d | 32.5d | SSH-Construction Manhours [7500 h] | 5,000 |  |
| 1.4.2.7.4.125 |  | Testing & commissioning of LS submersible pumps LS12 | 31.25d | 2012-09-15 | 2012-10-13 | 1.4.2.7.4.124 SS+50d | 37.5d | 7.5d | SSH-Construction Manhours [7500 h] | 5,000 |  |
|  | 6 | **Transformers** |  | 2011-12-21 | 2012-06-16 |  |  |  |  |  |  |
| 1.4.2.7.4.140 |  | Constrcution of transformer foundations | 150d | 2011-12-21 | 2012-05-08 | 1.4.2.7.4.090 SS | 122.5d | 0d | SSH-Construction Manhours [120000 h] | 193,800 |  |
| 1.4.2.7.4.150 |  | Install transformer SS4 | 12.5d | 2012-05-31 | 2012-06-12 | 1.4.2.7.4.140 SS+60d, 1.3.2.6.020, 1.4.2.7.4.070 SS+15d, 1.3.2.6.030, 1.4.2.7.4.071 | 38.25d | 0d | SSH-Construction Manhours [6000 h] | 34,800 |  |
| 1.4.2.7.4.152 |  | Install transformer SS5 | 12.5d | 2012-05-31 | 2012-06-12 | 1.4.2.7.4.072 SS+12.5d, 1.3.2.6.020, 1.4.2.7.4.073 | 37.75d | 0d | SSH-Construction Manhours [6000 h] | 34,800 |  |
| 1.4.2.7.4.151 |  | Testing & commissioning of transformer SS4 | 3.75d | 2012-06-12 | 2012-06-16 | 1.4.2.7.4.150 | 38.25d | 0d | SSH-Construction Manhours [900 h] | 30,000 |  |
| 1.4.2.7.4.153 |  | Testing & commissioning of transformer SS5 | 3.75d | 2012-06-12 | 2012-06-16 | 1.4.2.7.4.152 | 37.75d | 0d | SSH-Construction Manhours [900 h] | 30,000 | 0.0088619018 |

| ID | WBS | Activity | Duration | Start | Finish | Predecessors | Total float | Free float | Resources | Cost | QTY |
| --- | --- | --- | --- | --- | --- | --- | --- | --- | --- | --- | --- |
|  | 7 | **Automatic Transfer Switches - ATS-Fire Alarm System** |  | 2012-07-09 | 2012-09-09 |  |  |  |  |  |  |
| 1.4.2.7.4.176 |  | Install ATS-Fire Alarm System LS9 | 15d | 2012-07-09 | 2012-07-23 | 1.4.2.7.4.126 SS+12.5d | 56d | 0d | SSH-Construction Manhours [6000 h] | 28,125 |  |
| 1.4.2.7.4.177 |  | Testing & commissioning of ATS-LS9 | 10d | 2012-07-18 | 2012-07-28 | 1.4.2.7.4.176 SS+10d | 121d | 91d | SSH-Construction Manhours [3200 h] | 7,500 | 0.0022154755 |
| 1.4.2.7.4.174 |  | Install ATS-Fire Alarm System LS12 | 15d | 2012-07-30 | 2012-08-12 | 1.4.2.7.4.124 SS, 1.3.2.7.2.030 | 35d | 0d | SSH-Construction Manhours [6000 h] | 28,125 |  |
| 1.4.2.7.4.170 |  | Install ATS-Fire Alarm System -LS10 | 15d | 2012-08-05 | 2012-08-18 | 1.3.2.7.2.020, 1.4.2.7.4.120 SS+31.25d | 37.5d | 0d | SSH-Construction Manhours [6000 h] | 28,125 |  |
| 1.4.2.7.4.175 |  | Testing & commissioning of ATS-LS12 | 10d | 2012-08-08 | 2012-08-16 | 1.4.2.7.4.174 SS+10d | 98.75d | 68.75d | SSH-Construction Manhours [2400 h] | 7,500 |  |
| 1.4.2.7.4.171 |  | Testing & commissioning of ATS-LS10 | 10d | 2012-08-14 | 2012-08-22 | 1.4.2.7.4.170 SS+10d, 1.4.2.7.4.191 SS | 92.5d | 62.5d | SSH-Construction Manhours [3200 h] | 7,500 |  |
| 1.4.2.7.4.172 |  | Install ATS-Fire Alarm System LS11 | 15d | 2012-08-22 | 2012-09-04 | 1.4.2.7.4.122 SS+50d | 30d | 0d | SSH-Construction Manhours [6000 h] | 28,125 |  |
| 1.4.2.7.4.173 |  | Testing & commissioning of ATS-LS11 | 10d | 2012-09-01 | 2012-09-09 | 1.4.2.7.4.172 SS+10d | 73.75d | 43.75d | SSH-Construction Manhours [2400 h] | 7,500 |  |
|  | 8 | **Switchboards** |  | 2012-06-16 | 2012-06-26 |  |  |  |  |  |  |
| 1.4.2.7.4.190 |  | Install switchboards SS4 | 7.5d | 2012-06-16 | 2012-06-23 | 1.3.2.7.3.030, 1.4.2.7.4.151 | 38.25d | 0d | SSH-Construction Manhours [4800 h] | 56,250 |  |
| 1.4.2.7.4.192 |  | Install switchboards SS5 | 7.5d | 2012-06-16 | 2012-06-23 | 1.4.2.7.4.152 SS+10d, 1.3.2.7.3.030, 1.4.2.7.4.153 | 37.75d | 0d | SSH-Construction Manhours [4800 h] | 56,250 |  |
| 1.4.2.7.4.191 |  | Testing & commissioning of switchboards SS4 | 3.75d | 2012-06-23 | 2012-06-26 | 1.4.2.7.4.190 | 38.25d | 0d | SSH-Construction Manhours [2000 h] | 12,500 |  |
| 1.4.2.7.4.193 |  | Testing & commissioning of switchboards SS5 | 3.75d | 2012-06-23 | 2012-06-26 | 1.4.2.7.4.192 | 37.75d | 0d | SSH-Construction Manhours [2000 h] | 12,500 | 0.0036924591 |
|  | 9 | **Main distribution Panel Boards** |  | 2012-06-26 | 2012-07-07 |  |  |  |  |  |  |
| 1.4.2.7.4.210 |  | Install main distribution panel board SS4 | 7.5d | 2012-06-26 | 2012-07-03 | 1.4.2.7.4.070 SS, 1.4.2.7.4.190 SS+6d, 1.4.2.7.4.192, 1.3.2.7.4.030, 1.4.2.7.4.191 | 38.25d | 0d | SSH-Construction Manhours [4800 h] | 4,000 |  |
| 1.4.2.7.4.212 |  | Install main distribution panel board SS5 | 7.5d | 2012-06-26 | 2012-07-03 | 1.4.2.7.4.192 SS+6.25d, 1.4.2.7.4.070, 1.4.2.7.4.210 SS, 1.4.2.7.4.193 | 37.75d | 0d | SSH-Construction Manhours [4800 h] | 4,000 |  |
| 1.4.2.7.4.211 |  | Testing & commissioning of panel board SS4 | 3.75d | 2012-07-03 | 2012-07-07 | 1.4.2.7.4.210, 1.4.2.7.4.071 SS, 1.4.2.7.4.151 SS | 38.25d | 0d | SSH-Construction Manhours [900 h] | 2,500 |  |
| 1.4.2.7.4.213 |  | Testing & commissioning of panel board SS5 | 3.75d | 2012-07-03 | 2012-07-07 | 1.4.2.7.4.212 | 37.75d | 0d | SSH-Construction Manhours [900 h] | 2,500 | 0.0007384918 |
|  | 10 | **Circuit Breakers** |  | 2012-07-07 | 2012-07-17 |  |  |  |  |  |  |
| 1.4.2.7.4.230 |  | Install circuit breaker SS4 | 7.5d | 2012-07-07 | 2012-07-14 | 1.4.2.7.4.210 SS+6d, 1.3.2.7.1.030, 1.4.2.7.4.211 | 38.25d | 0d | SSH-Construction Manhours [3600 h] | 45,000 |  |
| 1.4.2.7.4.232 |  | Install circuit breaker SS5 | 7.5d | 2012-07-07 | 2012-07-14 | 1.4.2.7.4.212 SS+5d, 1.3.2.7.1.030, 1.4.2.7.4.230 SS, 1.4.2.7.4.213 | 37.75d | 0d | SSH-Construction Manhours [3600 h] | 45,000 |  |
| 1.4.2.7.4.231 |  | Testing & commissioning of circuit breaker SS4 | 3.75d | 2012-07-14 | 2012-07-17 | 1.4.2.7.4.230 | 38.25d | 0d | SSH-Construction Manhours [900 h] | 10,000 |  |
| 1.4.2.7.4.233 |  | Testing & commissioning of circuit breaker SS5 | 3.75d | 2012-07-14 | 2012-07-17 | 1.4.2.7.4.232 | 37.75d | 0d | SSH-Construction Manhours [900 h] | 10,000 | 0.0029539673 |

| ID | WBS | Activity | Duration | Start | Finish | Predecessors | Total float | Free float | Resources | Cost | QTY |
| --- | --- | --- | --- | --- | --- | --- | --- | --- | --- | --- | --- |
|  | 11 | **Annunciator Panel** |  | 2012-07-17 | 2012-07-28 |  |  |  |  |  |  |
| 1.4.2.7.4.250 |  | Install annunciator panel SS4 | 7.5d | 2012-07-17 | 2012-07-24 | 1.4.2.7.4.190, 1.3.2.7.5.030, 1.4.2.7.4.230, 1.4.2.7.4.231 | 38.25d | 0d | SSH-Construction Manhours [3600 h] | 22,500 |  |
| 1.4.2.7.4.252 |  | Install annunciator panel SS5 | 7.5d | 2012-07-17 | 2012-07-24 | 1.4.2.7.4.232, 1.4.2.7.4.192, 1.4.2.7.4.030, 1.4.2.7.4.233 | 37.75d | 0d | SSH-Construction Manhours [3600 h] | 22,500 |  |
| 1.4.2.7.4.251 |  | Testing & commissioning of annunciator panel SS4 | 3.75d | 2012-07-24 | 2012-07-28 | 1.4.2.7.4.250 | 38.25d | 0d | SSH-Construction Manhours [900 h] | 5,000 |  |
| 1.4.2.7.4.253 |  | Testing & commissioning of annunciator panel SS5 | 3.75d | 2012-07-24 | 2012-07-28 | 1.4.2.7.4.252 | 37.75d | 0d | SSH-Construction Manhours [900 h] | 5,000 | 0.0014769836 |
|  | 12 | **Battery Bank & Battery Charger with UPS** |  | 2012-07-28 | 2012-08-07 |  |  |  |  |  |  |
| 1.4.2.7.4.270 |  | Install battery bank & battery charger with system SS4 | 7.5d | 2012-07-28 | 2012-08-04 | 1.4.2.7.4.250 SS+6d, 1.3.2.7.6.030, 1.4.2.7.4.251 | 38.25d | 0d | SSH-Construction Manhours [3600 h] | 45,700 |  |
| 1.4.2.7.4.272 |  | Install battery bank & battery charger with system SS5 | 7.5d | 2012-07-28 | 2012-08-04 | 1.4.2.7.4.252 SS+6.25d, 1.4.2.7.4.253 | 37.75d | 0d | SSH-Construction Manhours [3600 h] | 45,700 |  |
| 1.4.2.7.4.271 |  | Testing & commissioning of battery system SS4 | 3.75d | 2012-08-04 | 2012-08-07 | 1.4.2.7.4.270, 1.4.2.7.4.251 SS | 38.25d | 0.25d | SSH-Construction Manhours [1600 h] | 15,100 |  |
| 1.4.2.7.4.273 |  | Testing & commissioning of battery system SS5 | 3.75d | 2012-08-04 | 2012-08-07 | 1.4.2.7.4.272, 1.4.2.7.4.253 | 37.75d | 0d | SSH-Construction Manhours [1600 h] | 15,100 | 0.0044604906 |
|  | 06 | **Grounding Cables** |  | 2011-12-21 | 2012-05-30 |  |  |  |  |  |  |
| 1.4.2.7.5.010 |  | Excavation of trench for grounding cables | 75d | 2011-12-21 | 2012-02-28 | 1.4.2.7.4.140 SS | 122.5d | 0d | SSH-Construction Manhours [36000 h] | 25,000 |  |
| 1.4.2.7.5.030 |  | Install grounding cables | 56.25d | 2012-02-12 | 2012-04-03 | 1.3.2.7.7.030, 1.4.2.7.5.010 SS+56.25d | 122.5d | 0d | SSH-Construction Manhours [64800 h] | 60,340 |  |
| 1.4.2.7.5.040 |  | Testing & commissioning of grounding cables | 31.25d | 2012-03-29 | 2012-04-26 | 1.4.2.7.5.030 SS+50d | 122.5d | 0d | SSH-Construction Manhours [10000 h] | 15,000 | 0.0044309509 |
| 1.4.2.7.5.020 |  | Supply/backfilling/compaction of grounding cable trench | 37.5d | 2012-04-26 | 2012-05-30 | 1.4.2.7.5.040 SS+30d | 122.5d | 84.5d | SSH-Construction Manhours [18000 h] | 20,000 |  |
|  | 9 | **Communication Works & Duct Banks** |  | 2012-01-15 | 2012-09-20 |  |  |  |  |  |  |
|  | 1 | **Communication works & Ductbanks** |  | 2012-01-15 | 2012-09-20 |  |  |  |  |  |  |
| 1.4.2.8.1.010 |  | Excavation of telecomm ductbanks & trench Zone3 -A3-1 | 18.75d | 2012-01-15 | 2012-02-01 | 1.3.3.2.1.030, 1.4.2.7.1.010 SS | 88d | 0d | SSH-Construction Manhours [10500 h]; Excavator [150 h]; Dump Truck [150 h] | 32,900 |  |
| 1.4.2.8.1.040 |  | Construction of comm concrete ductbanks | 75d | 2012-01-15 | 2012-03-25 | 1.4.2.8.1.010 SS | 188d | 0d | SSH-Construction Manhours [90000 h] | 1,642,811 |  |
| 1.4.2.8.1.050 |  | Install copper cable manholes | 75d | 2012-01-15 | 2012-03-25 | 1.4.2.8.1.040 SS | 188d | 0d | SSH-Construction Manhours [19171.6 h] | 156,000 |  |
| 1.4.2.8.1.100 |  | Install red tiles /cable markers | 62.5d | 2012-01-29 | 2012-03-27 | 1.4.2.8.1.050 SS+15d | 229.25d | 172.5d | SSH-Construction Manhours [20000 h] | 101,722 |  |
| 1.4.2.8.1.011 |  | Excavation of telecomm ductbanks & trench Zone3 -A3-2 | 25d | 2012-02-01 | 2012-02-25 | 1.4.2.8.1.010 | 88d | 0d | SSH-Construction Manhours [10000 h]; Dump Truck [200 h]; Excavator [200 h] | 32,900 |  |
| 1.4.2.8.1.070 |  | Install comm subduct materials | 50d | 2012-02-13 | 2012-03-31 | 1.4.2.8.1.050 SS+31.25d | 200.5d | 143.75d | SSH-Construction Manhours [30906.1 h]; Cable Puller [400 h] | 240,000 |  |
| 1.4.2.8.1.020 |  | Install comm conduits & fittings-Zone 3 - A3-1 | 22.5d | 2012-02-19 | 2012-03-11 | 1.4.2.8.1.010, 1.3.3.2.3.030, 1.3.3.2.4.030 | 95.5d | 0d | SSH-Construction Manhours [22500 h] | 24,286 |  |
| 1.4.2.8.1.012 |  | Excavation of telecomm ductbanks & trench Zone3 -A3-3 | 25d | 2012-02-25 | 2012-03-19 | 1.4.2.8.1.011 | 88d | 0d | SSH-Construction Manhours [20000 h]; Excavator [200 h]; Dump Truck [200 h] | 32,900 |  |
| 1.4.2.8.1.021 |  | Install comm conduits & fittings-Zone 3 - A3-2 | 27.5d | 2012-02-25 | 2012-03-21 | 1.4.2.8.1.011 | 93d | 0d | SSH-Construction Manhours [22000 h] | 24,286 |  |
| 1.4.2.8.1.030 |  | Install comm manholes-Zone 3 - A3-1(5) | 18.75d | 2012-03-01 | 2012-03-19 | 1.4.2.8.1.020 SS+12.5d, 1.3.3.2.7.030 | 95.5d | 36.25d | SSH-Construction Manhours [15000 h] | 50,700 |  |
| 1.4.2.8.1.013 |  | Excavation of telecomm ductbanks & trench Zone3 -A3-4 | 12.5d | 2012-03-19 | 2012-03-31 | 1.4.2.8.1.012 | 126.75d | 0d | SSH-Construction Manhours [10000 h]; Dump Truck [100 h]; Excavator [100 h] | 32,900 |  |
| 1.4.2.8.1.022 |  | Install comm conduits & fittings-Zone 3 - A3-3 | 27.5d | 2012-03-19 | 2012-04-14 | 1.4.2.8.1.012 | 88d | 0d | SSH-Construction Manhours [22000 h] | 24,286 |  |
| 1.4.2.8.1.031 |  | Install comm manholes-Zone 3 - A3-2 (5) | 18.75d | 2012-03-21 | 2012-04-08 | 1.4.2.8.1.021 | 93d | 33.75d | SSH-Construction Manhours [15000 h] | 50,700 |  |
| 1.4.2.8.1.060 |  | Supp/backfilling/compaction of comm trench | 43.75d | 2012-03-25 | 2012-05-05 | 1.4.2.8.1.050 | 188d | 131.25d | SSH-Construction Manhours [15021 h] | 317,260 |  |
| 1.4.2.8.1.014 |  | Excavation of telecomm ductbanks & trench Zone3 -A3-5 | 12.5d | 2012-03-31 | 2012-04-11 | 1.4.2.8.1.013 | 130.5d | 0d | SSH-Construction Manhours [10000 h]; Excavator [100 h]; Dump Truck [100 h] | 32,900 |  |
| 1.4.2.8.1.023 |  | Install comm conduits & fittings-Zone 3 - A3-4 | 15d | 2012-03-31 | 2012-04-14 | 1.4.2.8.1.013 | 126.75d | 0d | SSH-Construction Manhours [12000 h] | 24,286 |  |
| 1.4.2.8.1.015 |  | Excavation of telecomm ductbanks & trench Zone2 | 12.5d | 2012-04-11 | 2012-04-23 | 1.4.2.8.1.014 | 130.5d | 0d | SSH-Construction Manhours [10000 h]; Dump Truck [100 h]; Excavator [100 h] | 32,900 |  |
| 1.4.2.8.1.024 |  | Install comm conduits & fittings-Zone 3 - A3-5 | 15d | 2012-04-11 | 2012-04-25 | 1.4.2.8.1.014 | 138d | 0d | SSH-Construction Manhours [12000 h] | 24,286 |  |
| 1.4.2.8.1.032 |  | Install comm manholes-Zone 3 - A3-3 (7) | 26.25d | 2012-04-14 | 2012-05-08 | 1.4.2.8.1.022 | 88d | 28.75d | SSH-Construction Manhours [21000 h] | 70,980 |  |
| 1.4.2.8.1.033 |  | Install comm manholes-Zone 3 - A3-4 (5) | 18.75d | 2012-04-14 | 2012-05-01 | 1.4.2.8.1.023 | 126.75d | 67.5d | SSH-Construction Manhours [15000 h] | 50,700 |  |
| 1.4.2.8.1.082 |  | Install FOC [Fiber Optic Cable] Zone3 - A3-1 | 18.75d | 2012-04-22 | 2012-05-09 | 1.4.2.8.1.030, 1.3.3.1.1.030 | 59.25d | 0d | SSH-Construction Manhours [32000 h]; Cable Puller [150 h] | 94,285 |  |
| 1.4.2.8.1.016 |  | Excavation of telecomm ductbanks & trench Zone4 | 7.5d | 2012-04-23 | 2012-04-30 | 1.4.2.8.1.015 | 158d | 0d | SSH-Construction Manhours [6000 h]; Excavator [60 h]; Dump Truck [60 h] | 32,900 |  |
| 1.4.2.8.1.025 |  | Install comm conduits & fittings-Zone 2 | 15d | 2012-04-23 | 2012-05-07 | 1.4.2.8.1.015 | 130.5d | 0d | SSH-Construction Manhours [9600 h] | 24,286 |  |
| 1.4.2.8.1.034 |  | Install comm manholes-Zone 3 - A3-5 (2) | 7.5d | 2012-04-25 | 2012-05-02 | 1.4.2.8.1.024 | 138d | 78.75d | SSH-Construction Manhours [6000 h] | 20,280 |  |
| 1.4.2.8.1.026 |  | Install comm conduits & fittings-Zone 4 | 15d | 2012-04-30 | 2012-05-14 | 1.4.2.8.1.016 | 158d | 0d | SSH-Construction Manhours [9600 h] | 24,286 |  |
| 1.4.2.8.1.035 |  | Install comm manholes-Zone 2 (4) | 15d | 2012-05-07 | 2012-05-21 | 1.4.2.8.1.025 | 130.5d | 71.25d | SSH-Construction Manhours [12000 h] | 40,560 |  |
| 1.4.2.8.1.083 |  | Install FOC [Fiber Optic Cable] Zone3 - A3-2 | 27.5d | 2012-05-09 | 2012-06-04 | 1.4.2.8.1.031, 1.4.2.8.1.082 | 59.25d | 0d | SSH-Construction Manhours [22000 h]; Cable Puller [220 h] | 94,285 |  |
| 1.4.2.8.1.036 |  | Install comm manholes-Zone 4 (2) | 7.5d | 2012-05-14 | 2012-05-21 | 1.4.2.8.1.026 | 158d | 98.75d | SSH-Construction Manhours [6000 h] | 20,280 |  |
| 1.4.2.8.1.084 |  | Install FOC [Fiber Optic Cable] Zone3 - A3-3 | 31.25d | 2012-06-04 | 2012-07-03 | 1.4.2.8.1.032, 1.4.2.8.1.083 | 59.25d | 0d | SSH-Construction Manhours [25000 h]; Cable Puller [250 h] | 94,285 |  |
| 1.4.2.8.1.090 |  | Install comm grounding system | 37.5d | 2012-06-25 | 2012-07-30 | 1.4.2.8.1.040 SS+90d, 1.3.3.2.6.030 | 150.5d | 56.25d | SSH-Construction Manhours [18000 h]; Cable Puller [300 h] | 75,000 |  |
| 1.4.2.8.1.085 |  | Install FOC [Fiber Optic Cable] Zone3 - A3-4 | 12.5d | 2012-07-03 | 2012-07-15 | 1.4.2.8.1.033, 1.4.2.8.1.084 | 59.25d | 0d | SSH-Construction Manhours [6000 h]; Cable Puller [100 h] | 94,285 |  |
| 1.4.2.8.1.086 |  | Install FOC [Fiber Optic Cable] Zone3 - A3-5 | 12.5d | 2012-07-15 | 2012-07-26 | 1.4.2.8.1.034, 1.4.2.8.1.085 | 59.25d | 0d | SSH-Construction Manhours [6000 h]; Cable Puller [100 h] | 94,285 |  |
| 1.4.2.8.1.055 |  | Install comm copper cables closure | 37.5d | 2012-07-19 | 2012-08-23 | 1.4.2.8.1.050 SS+45d, 1.3.3.2.5.030, 1.3.3.1.3.030 | 69.25d | 12.5d | SSH-Construction Manhours [9585.81 h] | 73,000 |  |
| 1.4.2.8.1.080 |  | Install comm copper cables | 50d | 2012-07-19 | 2012-09-04 | 1.4.2.8.1.070 SS+25d, 1.3.3.1.4.030 | 56.75d | 0d | SSH-Construction Manhours [19939.5 h] | 609,710 |  |
| 1.4.2.8.1.087 |  | Install FOC [Fiber Optic Cable] Zone2 | 27.5d | 2012-07-26 | 2012-08-21 | 1.4.2.8.1.035, 1.4.2.8.1.086 | 59.25d | 0d | SSH-Construction Manhours [17600 h]; Cable Puller [220 h] | 94,285 |  |
| 1.4.2.8.1.088 |  | Install FOC [Fiber Optic Cable] Zone4 | 12.5d | 2012-08-21 | 2012-09-02 | 1.4.2.8.1.036, 1.4.2.8.1.087 | 59.25d | 2.5d | SSH-Construction Manhours [10000 h]; Cable Puller [100 h] | 94,285 |  |
| 1.4.2.8.1.110 |  | Testing/commissioning of comm system | 17.5d | 2012-09-04 | 2012-09-20 | 1.4.2.8.1.082 SS+31.25d, 1.4.2.8.1.100, 1.4.2.8.1.088, 1.4.2.8.1.080, 1.4.2.8.1.060, 1.4.2.8.1.055 | 56.75d | 0d | SSH-Construction Manhours [21000 h] | 20,000 |  |

| ID | WBS | Activity | Duration | Start | Finish | Predecessors | Total float | Free float | Resources | Cost | QTY |
| --- | --- | --- | --- | --- | --- | --- | --- | --- | --- | --- | --- |
|  | 3 | **BUILDING WORKS** |  | 2011-07-26 | 2012-11-20 |  |  |  |  |  |  |
|  | 1 | **Substations** |  | 2011-08-08 | 2012-08-21 |  |  |  |  |  |  |
|  | 1 | **Substation # 4** |  | 2011-08-08 | 2012-08-21 |  |  |  |  |  |  |
|  | 1 | **Civil Works** |  | 2011-08-08 | 2012-01-08 |  |  |  |  |  |  |
| 1.4.3.1.1.010 |  | Excavation leveling & cpmpactionfor SS4 fdns | 30d | 2011-08-08 | 2011-09-04 | 1.2.6.200 | 40.25d | 0d | SSH-Construction Manhours [9585.81 h]; Excavator [240 h]; Dump Truck [240 h] | 8,200 |  |
| 1.4.3.1.1.060 |  | backfill/compaction | 25d | 2011-12-17 | 2012-01-08 | 1.4.3.1.1.050 | 263.75d | 85d | SSH-Construction Manhours [7988.18 h]; Dump Truck [200 h]; Compactor [200 h] | 94,010 | 0.0277702463 |
|  | 2 | **Structural Works** |  | 2011-08-22 | 2012-02-15 |  |  |  |  |  |  |
| 1.4.3.1.1.020 |  | Install RSB/FW/concrete fdns | 50d | 2011-08-22 | 2011-10-06 | 1.4.3.1.1.010 SS+15d | 40.25d | 0d | SSH-Construction Manhours [100000 h] | 49,920 |  |
| 1.4.3.1.1.030 |  | Install RSB/FW/concrete for ground beams | 50d | 2011-09-14 | 2011-10-30 | 1.4.3.1.1.020 SS+25d | 40.25d | 0d | SSH-Construction Manhours [100000 h] | 21,840 |  |
| 1.4.3.1.1.040 |  | Install RSB/FW/concrete for equipment fdns | 50d | 2011-10-08 | 2011-11-22 | 1.4.3.1.1.030 SS+25d | 40.25d | 0d | SSH-Construction Manhours [69123.4 h] | 41,600 |  |
| 1.4.3.1.1.050 |  | Install RSB/FW/concrete for SS4 columns | 50d | 2011-10-31 | 2011-12-15 | 1.4.3.1.1.040 SS+25d | 40.25d | 0d | SSH-Construction Manhours [100000 h] | 27,040 |  |
| 1.4.3.1.1.070 |  | Install RSB/FW/concrete for roof beams | 50d | 2011-11-23 | 2012-01-08 | 1.4.3.1.1.050 SS+25d | 40.25d | 0d | SSH-Construction Manhours [100000 h] | 66,560 |  |
| 1.4.3.1.1.080 |  | Install RSB/FW/concrete for SS4 roof slab | 50d | 2011-11-23 | 2012-01-08 | 1.4.3.1.1.070 SS | 40.25d | 1.25d | SSH-Construction Manhours [100000 h] | 569,500 |  |
| 1.4.3.1.1.090 |  | Install CMU blocks | 40d | 2012-01-10 | 2012-02-15 | 1.4.3.1.1.080 SS+50d, 1.3.1.3.030, 1.2.5.030 | 39d | 0d | SSH-Construction Manhours [38400 h] | 78,660 | 0.0232359065 |
|  | 3 | **Architectural Works** |  | 2012-01-24 | 2012-04-08 |  |  |  |  |  |  |
| 1.4.3.1.1.100 |  | Install Plastering work | 40d | 2012-01-24 | 2012-02-29 | 1.4.3.1.1.090 SS+15d | 39d | 0d | SSH-Construction Manhours [25600 h] | 45,000 |  |
| 1.4.3.1.1.110 |  | Install floor finishing works - [Tiling] | 30d | 2012-02-07 | 2012-03-05 | 1.4.3.1.1.100 SS+15d, 1.3.1.2.030 | 39d | 0d | SSH-Construction Manhours [19200 h] | 75,500 |  |
| 1.4.3.1.1.120 |  | Install wall finishing works | 30d | 2012-02-21 | 2012-03-19 | 1.4.3.1.1.110 SS+15d, 1.3.1.2.030, 1.3.1.6.220 | 39d | 0d | SSH-Construction Manhours [19200 h] | 88,000 |  |
| 1.4.3.1.1.130 |  | Install roof water proofing system | 25d | 2012-03-01 | 2012-03-24 | 1.4.3.1.1.120 SS+10d | 39d | 0d | SSH-Construction Manhours [7500.44 h] | 110,600 |  |
| 1.4.3.1.1.125 |  | Install Ceiling finishing work | 30d | 2012-03-03 | 2012-03-29 | 1.4.3.1.1.120 SS, 1.3.1.6.240 | 206.25d | 27.5d | SSH-Construction Manhours [14400 h] | 45,000 | 0.0044309509 |
| 1.4.3.1.1.140 |  | Install painting works | 15d | 2012-03-15 | 2012-03-28 | 1.4.3.1.1.130 SS+15d | 39d | 1.25d | SSH-Construction Manhours [9585.81 h] | 50,000 |  |
| 1.4.3.1.1.150 |  | Install doors & windows with frames | 12.5d | 2012-03-28 | 2012-04-08 | 1.4.3.1.1.140 SS, 1.4.3.1.1.125 SS, 1.4.3.1.1.060, 1.3.1.4.030, 1.3.1.4.060, 1.3.1.6.260, 1.3.1.6.280 | 178.75d | 140.75d | SSH-Construction Manhours [4800 h] | 72,400 |  |
|  | 4 | **Plumbing Works** |  | 2012-01-31 | 2012-03-29 |  |  |  |  |  |  |
| 1.4.3.1.1.210 |  | Install plumbing works | 60d | 2012-01-31 | 2012-03-27 | 1.4.3.1.1.100 SS, 1.3.5.2.3.030 | 38d | 0d | SSH-Construction Manhours [48000 h] | 25,500 |  |
| 1.4.3.1.1.220 |  | Install eye wahs & shower | 18d | 2012-03-13 | 2012-03-29 | 1.4.3.1.1.210 SS+45d | 188.75d | 150.75d | SSH-Construction Manhours [7200 h] | 6,750 | 0.0019939279 |

| ID | WBS | Activity | Duration | Start | Finish | Predecessors | Total float | Free float | Resources | Cost | QTY |
| --- | --- | --- | --- | --- | --- | --- | --- | --- | --- | --- | --- |
|  | 5 | **Mechanical / HVAC Works** |  | 2012-01-31 | 2012-04-26 |  |  |  |  |  |  |
| 1.4.3.1.1.330 |  | Install ducting works & DDC | 45d | 2012-01-31 | 2012-03-13 | 1.4.3.1.1.210 SS | 38d | 0d | SSH-Construction Manhours [54000 h] | 35,000 |  |
| 1.4.3.1.1.340 |  | Install air inlet & outlet accs | 30d | 2012-02-19 | 2012-03-18 | 1.4.3.1.1.330 SS+20d | 158.75d | 0d | SSH-Construction Manhours [9000.53 h] | 25,000 |  |
| 1.4.3.1.1.350 |  | Install fire & volume dampers | 20d | 2012-02-28 | 2012-03-18 | 1.4.3.1.1.340 SS+10d | 158.75d | 0d | SSH-Construction Manhours [6400 h] | 25,000 |  |
| 1.4.3.1.1.360 |  | Install sandtrap louvers | 20d | 2012-03-08 | 2012-03-27 | 1.4.3.1.1.350 SS+10d | 158.75d | 0d | SSH-Construction Manhours [6400 h] | 5,600 |  |
| 1.4.3.1.1.370 |  | Install exhaust fan | 10d | 2012-03-18 | 2012-03-27 | 1.4.3.1.1.360 SS+10d | 158.75d | 0d | SSH-Construction Manhours [4800 h] | 7,595 |  |
| 1.4.3.1.1.380 |  | Install fire extinguishers | 10d | 2012-03-18 | 2012-03-27 | 1.4.3.1.1.370 SS | 191.75d | 153.75d | SSH-Construction Manhours [4800 h] | 15,500 |  |
| 1.4.3.1.1.310 |  | Install ACCU [Air cooled condencing unit] equipments | 15d | 2012-03-26 | 2012-04-08 | 1.4.3.1.1.370 SS+8d | 158.75d | 0d | SSH-Construction Manhours [12000 h] | 350,000 |  |
| 1.4.3.1.1.320 |  | Install AHU [Air Handling Unit] equipments with DDC panel | 15d | 2012-04-04 | 2012-04-17 | 1.4.3.1.1.310 SS+10d | 158.75d | 0d | SSH-Construction Manhours [12000 h] | 340,000 |  |
| 1.4.3.1.1.390 |  | Testing & balancing of HVAC system | 15d | 2012-04-14 | 2012-04-26 | 1.4.3.1.1.320 SS+10d | 158.75d | 120.75d | SSH-Construction Manhours [7200 h] | 7,500 | 0.0022154755 |
|  | 6 | **Electrical Works** |  | 2012-01-31 | 2012-08-21 |  |  |  |  |  |  |
| 1.4.3.1.1.410 |  | Install electrical conduits & fittings | 45d | 2012-01-31 | 2012-03-13 | 1.4.3.1.1.330 SS | 38d | 0d | SSH-Construction Manhours [25200 h] | 25,000 |  |
| 1.4.3.1.1.480 |  | Install cables trays | 60d | 2012-02-05 | 2012-04-01 | 1.4.3.1.1.410 SS+5d | 38d | 0d | SSH-Construction Manhours [38343.2 h] | 65,000 |  |
| 1.4.3.1.1.420 |  | Install cables & wires | 37.5d | 2012-02-19 | 2012-03-25 | 1.4.3.1.1.480 SS+15d | 38d | 0d | SSH-Construction Manhours [19200 h] | 15,000 |  |
| 1.4.3.1.1.430 |  | Install lighting fixtures | 37.5d | 2012-03-13 | 2012-04-17 | 1.4.3.1.1.420 SS+25d | 38d | 0d | SSH-Construction Manhours [14378.7 h] | 72,000 |  |
| 1.4.3.1.1.500 |  | Install grounding system | 25d | 2012-03-20 | 2012-04-12 | 1.4.3.1.1.480 SS+47.5d | 43d | 5d | SSH-Construction Manhours [7988.18 h] | 45,000 |  |
| 1.4.3.1.1.440 |  | Install Switchgear | 7.5d | 2012-04-17 | 2012-04-24 | 1.4.3.1.1.430, 1.4.3.1.1.500 | 38d | 0d | SSH-Construction Manhours [9585.81 h] | 52,000 |  |
| 1.4.3.1.1.450 |  | Install Package substation | 7.5d | 2012-04-28 | 2012-05-05 | 1.4.3.1.1.440 FS+3.75d | 38d | 0d | SSH-Construction Manhours [9585.81 h] | 20,750 |  |
| 1.4.3.1.1.460 |  | Install RMU | 18.75d | 2012-05-08 | 2012-05-26 | 1.4.3.1.1.450 FS+3.75d | 38d | 0d | SSH-Construction Manhours [11200 h] | 26,000 |  |
| 1.4.3.1.1.470 |  | Install Transformer | 12.5d | 2012-05-31 | 2012-06-12 | 1.4.3.1.1.460 FS+6.25d | 38d | 0d | SSH-Construction Manhours [6390.54 h] | 2,500 |  |
| 1.4.3.1.1.490 |  | Install FAS-Fire Alarm system & FACP | 18.75d | 2012-06-12 | 2012-06-30 | 1.4.3.1.1.470, 1.3.2.7.9.030 | 38d | 0d | SSH-Construction Manhours [15000 h] | 65,000 |  |
| 1.4.3.1.1.510 |  | Install switchboard | 7.5d | 2012-06-16 | 2012-06-23 | 1.4.3.1.1.470 FS+3.75d, 1.4.3.1.1.490 SS+3.75d | 38d | 0d | SSH-Construction Manhours [9585.81 h] | 210,000 |  |
| 1.4.3.1.1.520 |  | Install main distribution panel board | 7.5d | 2012-06-26 | 2012-07-03 | 1.4.3.1.1.510 FS+3.75d, 1.3.2.1.060 | 38d | 0d | SSH-Construction Manhours [9585.81 h] | 60,000 |  |
| 1.4.3.1.1.530 |  | Install circuit breaker | 7.5d | 2012-07-07 | 2012-07-14 | 1.4.3.1.1.520 FS+3.75d | 38d | 0d | SSH-Construction Manhours [4800 h] | 39,000 |  |
| 1.4.3.1.1.540 |  | Install annunciator panel | 7.5d | 2012-07-17 | 2012-07-24 | 1.4.3.1.1.530 FS+3.75d | 38d | 0d | SSH-Construction Manhours [4800 h] | 20,000 |  |
| 1.4.3.1.1.550 |  | Install batterybank | 7.5d | 2012-07-28 | 2012-08-04 | 1.4.3.1.1.540 FS+3.75d | 38d | 0d | SSH-Construction Manhours [4800 h] | 100,000 |  |
| 1.4.3.1.1.560 |  | Testing /commissioning of electrical system | 15d | 2012-08-04 | 2012-08-18 | 1.4.3.1.1.550, 1.4.2.7.4.271 SS, 1.2.8.020, 1.4.3.1.1.510 | 38d | 0d | SSH-Construction Manhours [9585.81 h] | 150,000 |  |
| 1.4.3.1.1.570 |  | Energize Substation 4 | 3.75d | 2012-08-18 | 2012-08-21 | 1.4.3.1.1.560, 1.4.3.1.1.380, 1.4.3.1.1.390, 1.4.3.1.1.220, 1.4.3.1.1.150, 1.4.3.1.1.640, 1.4.4.2.010, 1.4.3.1.1.510, 1.4.2.7.5.020 | 38d | 0.25d | SSH-Construction Manhours [1500.09 h] | 20,000 | 0.0059079345 |

| ID | WBS | Activity | Duration | Start | Finish | Predecessors | Total float | Free float | Resources | Cost | QTY |
| --- | --- | --- | --- | --- | --- | --- | --- | --- | --- | --- | --- |
|  | 7 | **Communication Works** |  | 2012-02-09 | 2012-07-19 |  |  |  |  |  |  |
| 1.4.3.1.1.610 |  | Install comm conduits & fittings | 45d | 2012-02-09 | 2012-03-22 | 1.4.3.1.1.410 SS+10d | 181.75d | 0d | SSH-Construction Manhours [28800 h] | 17,000 |  |
| 1.4.3.1.1.620 |  | Install comm cabinet & accs & Data interworks | 15d | 2012-03-08 | 2012-03-22 | 1.4.3.1.1.610 SS+30d | 181.75d | 112.5d | SSH-Construction Manhours [4800 h] | 75,500 |  |
| 1.4.3.1.1.630 |  | Install comm equipments & accs | 15d | 2012-07-01 | 2012-07-15 | 1.4.3.1.1.620 SS+10d, 1.3.3.1.2.030 | 69.25d | 0d | SSH-Construction Manhours [4800 h] | 185,000 |  |
| 1.4.3.1.1.640 |  | Install comm outlet & accs | 10d | 2012-07-10 | 2012-07-19 | 1.4.3.1.1.630 SS+10d | 69.25d | 31.25d | SSH-Construction Manhours [3200 h] | 3,000 | 0.0008861902 |
|  | 8 | **Pavement / Parking / Signs / Markings** |  | 2012-01-24 | 2012-04-02 |  |  |  |  |  |  |
| 1.4.3.1.1.710 |  | Install gravel pavement | 40d | 2012-01-24 | 2012-02-29 | 1.4.3.1.1.100 SS | 277.5d | 0d | SSH-Construction Manhours [28757.4 h] | 5,467 |  |
| 1.4.3.1.1.720 |  | Install 150mm thick concrete pavement | 30d | 2012-02-02 | 2012-02-29 | 1.4.3.1.1.710 SS+10d | 277.5d | 0d | SSH-Construction Manhours [24000 h] | 36,110 |  |
| 1.4.3.1.1.730 |  | Install 500mm thick general fill | 30d | 2012-02-12 | 2012-03-10 | 1.4.3.1.1.720 SS+10d | 277.5d | 0d | SSH-Construction Manhours [24000 h] | 17,400 |  |
| 1.4.3.1.1.740 |  | Install 200mm thk aggregate base coarse | 30d | 2012-02-21 | 2012-03-19 | 1.4.3.1.1.730 SS+10d | 277.5d | 0d | SSH-Construction Manhours [24000 h] | 9,048 |  |
| 1.4.3.1.1.750 |  | Install 120mm thk asphalt cncrt pavement | 20d | 2012-03-01 | 2012-03-19 | 1.4.3.1.1.740 SS+10d | 277.5d | 0d | SSH-Construction Manhours [16000 h] | 27,840 |  |
| 1.4.3.1.1.760 |  | Install shaded parking space | 18d | 2012-03-11 | 2012-03-27 | 1.4.3.1.1.750 SS+10d | 277.5d | 0d | SSH-Construction Manhours [5760 h] | 56,700 |  |
| 1.4.3.1.1.770 |  | Install road / park markings | 10d | 2012-03-20 | 2012-03-28 | 1.4.3.1.1.760 SS+10d | 277.5d | 0d | SSH-Construction Manhours [3200 h] | 37,500 |  |
| 1.4.3.1.1.780 |  | Install road / parking signs | 10d | 2012-03-25 | 2012-04-02 | 1.4.3.1.1.770 SS+5d | 277.5d |  | SSH-Construction Manhours [3195.27 h] | 7,560 | 0.0022331993 |
|  | 9 | **Perimeter Fence System** |  | 2012-03-01 | 2012-03-31 |  |  |  |  |  |  |
| 1.4.3.1.1.810 |  | Install perimeter fence type SSD-1 | 30d | 2012-03-01 | 2012-03-28 | 1.4.3.1.1.710 | 373d | 0d | SSH-Construction Manhours [14400 h] | 82,350 |  |
| 1.4.3.1.1.820 |  | Install perimeter gate SSD-1 10.5m wide 2 leaf | 10d | 2012-03-21 | 2012-03-31 | 1.4.3.1.1.810 SS+22d | 373d | 293d | SSH-Construction Manhours [6400 h] | 15,000 | 0.0044309509 |
|  | 10 | **Substation # 5** |  | 2011-08-08 | 2012-08-21 |  |  |  |  |  |  |
|  | 1 | **Civil Works** |  | 2011-08-08 | 2012-01-08 |  |  |  |  |  |  |
| 1.4.3.1.2.010 |  | Excavation leveling & compactionfor SS5 fdns | 30d | 2011-08-08 | 2011-09-04 | 1.4.3.1.1.010 SS, 1.2.6.200 | 60d | 0d | SSH-Construction Manhours [9585.81 h]; Excavator [240 h]; Dump Truck [240 h] | 8,200 |  |
| 1.4.3.1.2.060 |  | backfill/compaction | 25d | 2011-12-17 | 2012-01-08 | 1.4.3.1.2.050 | 261.25d | 60d | SSH-Construction Manhours [7988.18 h]; Dump Truck [200 h]; Compactor [200 h] | 94,010 | 0.0277702463 |
|  | 2 | **Structural Works** |  | 2011-08-22 | 2012-02-09 |  |  |  |  |  |  |
| 1.4.3.1.2.020 |  | Install RSB/FW/concrete fdns | 50d | 2011-08-22 | 2011-10-06 | 1.4.3.1.2.010 SS+15d | 60d | 0d | SSH-Construction Manhours [100000 h] | 49,920 |  |
| 1.4.3.1.2.030 |  | Install RSB/FW/concrete for ground beams | 50d | 2011-09-14 | 2011-10-30 | 1.4.3.1.2.020 SS+25d | 60d | 0d | SSH-Construction Manhours [100000 h] | 21,840 |  |
| 1.4.3.1.2.040 |  | Install RSB/FW/concrete for equipment fdns | 50d | 2011-10-08 | 2011-11-22 | 1.4.3.1.2.030 SS+25d | 60d | 0d | SSH-Construction Manhours [100000 h] | 41,600 |  |
| 1.4.3.1.2.050 |  | Install RSB/FW/concrete for SS5 columns | 50d | 2011-10-31 | 2011-12-15 | 1.4.3.1.2.040 SS+25d | 60d | 0d | SSH-Construction Manhours [100000 h] | 27,040 |  |
| 1.4.3.1.2.070 |  | Install RSB/FW/concrete for roof beams | 50d | 2011-10-31 | 2011-12-15 | 1.4.3.1.2.050 SS | 60d | 0d | SSH-Construction Manhours [100000 h] | 66,560 |  |
| 1.4.3.1.2.080 |  | Install RSB/FW/concrete for SS5 roof slab | 50d | 2011-11-23 | 2012-01-08 | 1.4.3.1.2.070 SS+25d | 60d | 0d | SSH-Construction Manhours [100000 h] | 569,500 |  |
| 1.4.3.1.2.090 |  | Install CMU blocks | 40d | 2012-01-04 | 2012-02-09 | 1.4.3.1.2.080 SS+45d | 60d | 0d | SSH-Construction Manhours [38400 h] | 78,660 | 0.0232359065 |

| ID | WBS | Activity | Duration | Start | Finish | Predecessors | Total float | Free float | Resources | Cost | QTY |
| --- | --- | --- | --- | --- | --- | --- | --- | --- | --- | --- | --- |
|  | 3 | **Architectural Works** |  | 2012-01-18 | 2012-03-18 |  |  |  |  |  |  |
| 1.4.3.1.2.100 |  | Install Plastering work | 40d | 2012-01-18 | 2012-02-23 | 1.4.3.1.2.090 SS+15d | 60d | 0d | SSH-Construction Manhours [32000 h] | 45,000 |  |
| 1.4.3.1.2.110 |  | Install finishing finishing works - [Tiling] | 30d | 2012-02-01 | 2012-02-28 | 1.4.3.1.2.100 SS+15d | 201.25d | 0d | SSH-Construction Manhours [19200 h] | 75,500 |  |
| 1.4.3.1.2.120 |  | Install wall finishing works | 30d | 2012-02-11 | 2012-03-08 | 1.4.3.1.2.110 SS+10d | 201.25d | 0d | SSH-Construction Manhours [19200 h] | 88,000 |  |
| 1.4.3.1.2.125 |  | Install ceiling finishing works | 30d | 2012-02-11 | 2012-03-08 | 1.4.3.1.2.120 SS | 226.25d | 25d | SSH-Construction Manhours [14378.7 h] | 45,000 | 0.0044309509 |
| 1.4.3.1.2.130 |  | Install roof water proofing system | 22.5d | 2012-02-20 | 2012-03-11 | 1.4.3.1.2.120 SS+10d | 201.25d | 0d | SSH-Construction Manhours [7200 h] | 110,600 |  |
| 1.4.3.1.2.140 |  | Install painting works | 15d | 2012-02-29 | 2012-03-13 | 1.4.3.1.2.130 SS+10d | 201.25d | 0d | SSH-Construction Manhours [6000 h] | 50,000 |  |
| 1.4.3.1.2.150 |  | Install doors & windows with frames | 15d | 2012-03-05 | 2012-03-18 | 1.4.3.1.2.140 SS+5d, 1.4.3.1.2.125 SS, 1.4.3.1.2.060 | 201.25d | 163.5d | SSH-Construction Manhours [4800 h] | 72,400 |  |
|  | 4 | **Plumbing Works** |  | 2012-01-31 | 2012-03-22 |  |  |  |  |  |  |
| 1.4.3.1.2.210 |  | Install plumbing works | 37.5d | 2012-01-31 | 2012-03-06 | 1.4.3.1.2.100 SS, 1.3.5.2.3.030 | 45.5d | 0d | SSH-Construction Manhours [22366.9 h] | 25,500 |  |
| 1.4.3.1.2.220 |  | Install eye wash & shower | 30d | 2012-02-23 | 2012-03-22 | 1.4.3.1.2.210 SS+25d | 196.75d | 159d | SSH-Construction Manhours [14378.7 h] | 6,750 | 0.0019939279 |
|  | 5 | **Mechanical / HVAC Works** |  | 2012-01-31 | 2012-05-06 |  |  |  |  |  |  |
| 1.4.3.1.2.330 |  | Install ducting works | 45d | 2012-01-31 | 2012-03-13 | 1.4.3.1.2.210 SS | 45.5d | 0d | SSH-Construction Manhours [38343.2 h] | 35,000 |  |
| 1.4.3.1.2.340 |  | Install air inlet & outlet accs | 20d | 2012-02-23 | 2012-03-13 | 1.4.3.1.2.330 SS+25d | 148.75d | 0d | SSH-Construction Manhours [16000 h] | 25,000 |  |
| 1.4.3.1.2.350 |  | Install fire & volume dampers | 20d | 2012-03-04 | 2012-03-22 | 1.4.3.1.2.340 SS+10d | 148.75d | 0d | SSH-Construction Manhours [9600 h] | 25,000 |  |
| 1.4.3.1.2.360 |  | Install sandtrap louvers | 17.5d | 2012-03-13 | 2012-03-29 | 1.4.3.1.2.350 SS+10d | 148.75d | 0d | SSH-Construction Manhours [7000 h] | 5,600 |  |
| 1.4.3.1.2.370 |  | Install exhaust fan | 10d | 2012-03-22 | 2012-04-01 | 1.4.3.1.2.360 SS+10d | 148.75d | 0d | SSH-Construction Manhours [4000 h] | 7,595 |  |
| 1.4.3.1.2.380 |  | Install fire extinguishers | 15d | 2012-03-22 | 2012-04-05 | 1.4.3.1.2.370 SS | 181.75d | 144d | SSH-Construction Manhours [9585.81 h] | 15,500 |  |
| 1.4.3.1.2.310 |  | Install ACCU equipments | 15d | 2012-03-31 | 2012-04-12 | 1.4.3.1.2.370 SS+8d | 148.75d | 0d | SSH-Construction Manhours [12000 h] | 350,000 |  |
| 1.4.3.1.2.320 |  | Install AHU equipments with DDC Panel | 15d | 2012-04-14 | 2012-04-26 | 1.4.3.1.2.310 SS+15d | 148.75d | 0d | SSH-Construction Manhours [12000 h] | 340,000 |  |
| 1.4.3.1.2.390 |  | Testing & balancing of HVAC system | 15d | 2012-04-23 | 2012-05-06 | 1.4.3.1.2.320 SS+10d | 148.75d | 111d | SSH-Construction Manhours [9000.53 h] | 7,500 | 0.0022154755 |
|  | 6 | **Electrical Works** |  | 2012-01-31 | 2012-08-21 |  |  |  |  |  |  |
| 1.4.3.1.2.410 |  | Install electrical conduits & fititings | 45d | 2012-01-31 | 2012-03-13 | 1.4.3.1.2.330 SS | 45.5d | 0d | SSH-Construction Manhours [28800 h] | 25,000 |  |
| 1.4.3.1.2.480 |  | Install cables trays | 60d | 2012-02-05 | 2012-04-01 | 1.4.3.1.2.410 SS+5d | 45.5d | 0d | SSH-Construction Manhours [19171.6 h] | 65,000 |  |
| 1.4.3.1.2.420 |  | Install cables & wires | 37.5d | 2012-02-19 | 2012-03-25 | 1.4.3.1.2.480 SS+15d | 45.5d | 0d | SSH-Construction Manhours [19200 h] | 15,000 |  |
| 1.4.3.1.2.430 |  | Install lighting fixtures | 37.5d | 2012-03-13 | 2012-04-17 | 1.4.3.1.2.420 SS+25d | 45.5d | 0d | SSH-Construction Manhours [10800 h] | 72,000 |  |
| 1.4.3.1.2.500 |  | Install grounding system | 25d | 2012-03-20 | 2012-04-12 | 1.4.3.1.2.480 SS+47.5d | 69.5d | 24d | SSH-Construction Manhours [9585.81 h] | 45,000 |  |
| 1.4.3.1.2.440 |  | Install switchgear | 7.5d | 2012-04-17 | 2012-04-24 | 1.4.3.1.2.430, 1.4.3.1.2.500 SS+6d | 45.5d | 0d | SSH-Construction Manhours [9600 h] | 52,000 |  |
| 1.4.3.1.2.450 |  | Install package substation | 7.5d | 2012-04-28 | 2012-05-05 | 1.4.3.1.2.440 FS+3.75d | 45.5d | 0d | SSH-Construction Manhours [12781.1 h] | 20,750 |  |
| 1.4.3.1.2.460 |  | Install RMU | 18.75d | 2012-05-08 | 2012-05-26 | 1.4.3.1.2.450 FS+3.75d | 45.5d | 0d | SSH-Construction Manhours [12781.1 h] | 26,000 |  |
| 1.4.3.1.2.470 |  | Install Transformer | 12.5d | 2012-05-31 | 2012-06-12 | 1.4.3.1.2.460 FS+6.25d | 45.5d | 0d | SSH-Construction Manhours [12781.1 h] | 2,500 |  |
| 1.4.3.1.2.490 |  | Install FAS-Fire Alarm System & FACP | 18.75d | 2012-06-12 | 2012-06-30 | 1.4.3.1.2.470 | 45.5d | 0d | SSH-Construction Manhours [15000 h] | 65,000 |  |
| 1.4.3.1.2.510 |  | Install switchboard | 7.5d | 2012-06-16 | 2012-06-23 | 1.4.3.1.2.470 FS+3.75d, 1.4.3.1.2.490 SS+3.75d | 45.5d | 0d | SSH-Construction Manhours [12781.1 h] | 210,000 |  |
| 1.4.3.1.2.520 |  | Install Main distribution panel board | 7.5d | 2012-06-26 | 2012-07-03 | 1.4.3.1.2.510 FS+3.75d | 45.5d | 0d | SSH-Construction Manhours [12781.1 h] | 60,000 |  |
| 1.4.3.1.2.530 |  | Install circuit breaker | 7.5d | 2012-07-07 | 2012-07-14 | 1.4.3.1.2.520 FS+3.75d | 45.5d | 0d | SSH-Construction Manhours [12781.1 h] | 39,000 |  |
| 1.4.3.1.2.540 |  | Install annunciator panel | 7.5d | 2012-07-17 | 2012-07-24 | 1.4.3.1.2.530 FS+3.75d | 45.5d | 0d | SSH-Construction Manhours [12781.1 h] | 20,000 |  |
| 1.4.3.1.2.550 |  | Install batterybank | 7.5d | 2012-07-28 | 2012-08-04 | 1.4.3.1.2.540 FS+3.75d | 45.5d | 7.75d | SSH-Construction Manhours [9585.81 h] | 100,000 |  |
| 1.4.3.1.2.560 |  | Testing /commissioning of electrical system | 15d | 2012-08-04 | 2012-08-18 | 1.4.3.1.2.550 SS, 1.4.2.7.4.273 SS, 1.4.3.1.2.540 SS | 37.75d | 0d | SSH-Construction Manhours [9000.53 h] | 150,000 |  |
| 1.4.3.1.2.570 |  | Energize Substation 5 | 3.75d | 2012-08-18 | 2012-08-21 | 1.4.3.1.2.560, 1.4.3.1.2.380, 1.4.3.1.2.390, 1.4.3.1.2.640, 1.4.3.1.2.780, 1.4.3.1.2.150, 1.4.3.1.2.220 | 37.75d | 0d | SSH-Construction Manhours [2400.14 h] | 20,000 | 0.0059079345 |

| ID | WBS | Activity | Duration | Start | Finish | Predecessors | Total float | Free float | Resources | Cost | QTY |
| --- | --- | --- | --- | --- | --- | --- | --- | --- | --- | --- | --- |
|  | 7 | **Communication Works** |  | 2012-01-31 | 2012-04-15 |  |  |  |  |  |  |
| 1.4.3.1.2.610 |  | Install comm conduits & fittings | 50d | 2012-01-31 | 2012-03-18 | 1.4.3.1.2.410 SS | 171.75d | 0d | SSH-Construction Manhours [19171.6 h] | 17,000 |  |
| 1.4.3.1.2.620 |  | Install comm cabinet & accs & data interworks | 20d | 2012-03-08 | 2012-03-27 | 1.4.3.1.2.610 SS+40d | 171.75d | 0d | SSH-Construction Manhours [9600 h] | 75,500 |  |
| 1.4.3.1.2.630 |  | Install comm equipments & accs | 20d | 2012-03-22 | 2012-04-10 | 1.4.3.1.2.620 SS+15d | 171.75d | 0d | SSH-Construction Manhours [19171.6 h] | 185,000 |  |
| 1.4.3.1.2.640 |  | Install comm outlet & accs | 10d | 2012-04-05 | 2012-04-15 | 1.4.3.1.2.630 SS+15d, 1.4.3.1.2.820 | 171.75d | 134d | SSH-Construction Manhours [8000 h] | 3,000 | 0.0008861902 |
|  | 8 | **Pavement / Parking / Signs / Markings** |  | 2012-01-18 | 2012-03-22 |  |  |  |  |  |  |
| 1.4.3.1.2.710 |  | Install gravel pavement | 40d | 2012-01-18 | 2012-02-23 | 1.4.3.1.2.100 SS | 181.25d | 0d | SSH-Construction Manhours [35200 h] | 5,467 |  |
| 1.4.3.1.2.720 |  | Install 150mm thick concrete pavement | 30d | 2012-01-28 | 2012-02-23 | 1.4.3.1.2.710 SS+10d | 197.25d | 0d | SSH-Construction Manhours [24000 h] | 36,110 |  |
| 1.4.3.1.2.730 |  | Install 500mm thick general fill | 30d | 2012-02-06 | 2012-03-04 | 1.4.3.1.2.720 SS+10d | 197.25d | 0d | SSH-Construction Manhours [21568.1 h] | 17,400 |  |
| 1.4.3.1.2.740 |  | Install 200mm thk aggregate base coarse | 25d | 2012-02-15 | 2012-03-08 | 1.4.3.1.2.730 SS+10d | 197.25d | 0d | SSH-Construction Manhours [21568.1 h] | 9,048 |  |
| 1.4.3.1.2.750 |  | Install 120mm thk asphalt cncrt pavement | 20d | 2012-02-25 | 2012-03-13 | 1.4.3.1.2.740 SS+10d | 197.25d | 0d | SSH-Construction Manhours [8000 h] | 27,840 |  |
| 1.4.3.1.2.760 |  | Install shaded parking space | 18.75d | 2012-02-29 | 2012-03-17 | 1.4.3.1.2.750 SS+5d | 197.25d | 0d | SSH-Construction Manhours [9000 h] | 56,700 |  |
| 1.4.3.1.2.770 |  | Install road / park markings | 15d | 2012-03-05 | 2012-03-19 | 1.4.3.1.2.760 SS+6d | 197.25d | 0d | SSH-Construction Manhours [7200 h] | 37,500 |  |
| 1.4.3.1.2.780 |  | Install road / parking signs | 15d | 2012-03-08 | 2012-03-22 | 1.4.3.1.2.770 SS+3d | 197.25d | 159.5d | SSH-Construction Manhours [7200 h] | 7,560 | 0.0022331993 |
|  | 9 | **Perimeter Fence System** |  | 2012-02-11 | 2012-03-27 |  |  |  |  |  |  |
| 1.4.3.1.2.810 |  | Install perimeter fence type SSD-1 | 45d | 2012-02-11 | 2012-03-22 | 1.4.3.1.2.710 SS+25d | 181.25d | 0d | SSH-Construction Manhours [18000 h] | 82,350 |  |
| 1.4.3.1.2.820 |  | Install periemter gate SSD-1 10.5m wide 2 leaf | 20d | 2012-03-10 | 2012-03-27 | 1.4.3.1.2.810 SS+30d | 181.25d | 9.5d | SSH-Construction Manhours [8000 h] | 15,000 | 0.0044309509 |
|  | 2 | **Exchange Building** |  | 2011-07-26 | 2012-10-04 |  |  |  |  |  |  |
|  | 1 | **Exchange Building # 1** |  | 2011-07-26 | 2012-10-04 |  |  |  |  |  |  |
|  | 1 | **Civil Works** |  | 2011-07-26 | 2012-01-02 |  |  |  |  |  |  |
| 1.4.3.2.1.010 |  | Site clearing / grubbing | 15d | 2011-07-26 | 2011-08-08 | 1.2.6.200 SS+18.75d | 51.5d | 0d | SSH-Construction Manhours [4800 h]; Grader [120 h]; Dump Truck [120 h] | 24,300 |  |
| 1.4.3.2.1.020 |  | Excavation leveling & compactionfor exchange bldg 1 fdns | 15d | 2011-07-31 | 2011-08-14 | 1.4.3.2.1.010 SS+6d | 51.5d | 0d | SSH-Construction Manhours [7200 h]; Excavator [120 h]; Dump Truck [120 h] | 21,750 |  |
| 1.4.3.2.1.030 |  | Backfill/compaction of exchange bldg fdns | 18.75d | 2011-12-15 | 2012-01-02 | 1.4.3.2.1.150 | 229.25d | 60d | SSH-Construction Manhours [10000 h]; Dump Truck [150 h]; Compactor [150 h] | 257,500 | 0.0760646572 |
|  | 2 | **Structural Works** |  | 2011-08-14 | 2012-05-02 |  |  |  |  |  |  |
| 1.4.3.2.1.110 |  | Install RSB/FW/concrete for fdns | 37.5d | 2011-08-14 | 2011-09-18 | 1.4.3.2.1.020 | 51.5d | 0d | SSH-Construction Manhours [112500 h] | 164,320 |  |
| 1.4.3.2.1.120 |  | Install RSB/FW/concrete for ground beams | 60d | 2011-08-14 | 2011-10-09 | 1.4.3.2.1.110 SS | 51.5d | 0d | SSH-Construction Manhours [120000 h] | 20,800 |  |
| 1.4.3.2.1.130 |  | Install RSB/FW/concrete for equipment fdns | 60d | 2011-09-11 | 2011-11-06 | 1.4.3.2.1.120 SS+30d | 51.5d | 0d | SSH-Construction Manhours [120000 h] | 10,400 |  |
| 1.4.3.2.1.140 |  | Install RSB/FW/concrete for columns | 60d | 2011-10-09 | 2011-12-04 | 1.4.3.2.1.130 SS+30d | 51.5d | 0d | SSH-Construction Manhours [120000 h] | 6,240 |  |
| 1.4.3.2.1.230 |  | Install embedded structural steel, anchor bolts,plates,angles | 120d | 2011-10-09 | 2012-01-29 | 1.4.3.2.1.130 SS+30d | 167d | 71.25d | SSH-Construction Manhours [82948.1 h] | 617,500 |  |
| 1.4.3.2.1.150 |  | Install RSB/FW/concrete for side walls | 60d | 2011-10-20 | 2011-12-15 | 1.4.3.2.1.140 SS+12.5d | 51.5d | 0d | SSH-Construction Manhours [96000 h] | 67,600 |  |
| 1.4.3.2.1.155 |  | Install structural steel structures | 60d | 2011-10-20 | 2011-12-15 | 1.4.3.2.1.150 SS | 81.5d | 30d | SSH-Construction Manhours [72004.2 h] | 700,000 | 0.2953967271 |
| 1.4.3.2.1.160 |  | Install RSB/FW/cncrt for suspended slab | 60d | 2011-11-17 | 2012-01-12 | 1.4.3.2.1.150 SS+30d, 1.4.3.2.1.155 SS | 51.5d | 0d | SSH-Construction Manhours [96000 h] | 15,600 |  |
| 1.4.3.2.1.170 |  | Install RSB/FW/cncrt for cable vault, SOG | 60d | 2011-12-05 | 2012-01-30 | 1.4.3.2.1.160 SS+18.75d | 51.5d | 0d | SSH-Construction Manhours [72004.2 h] | 58,240 |  |
| 1.4.3.2.1.180 |  | Install RSB/FW/cncrt for grade slab | 45d | 2012-01-02 | 2012-02-13 | 1.4.3.2.1.170 SS+30d | 150.75d | 84d | SSH-Construction Manhours [54003.2 h] | 3,120 |  |
| 1.4.3.2.1.190 |  | Install 150mm thk prefabricated wall panel | 30d | 2012-01-30 | 2012-02-27 | 1.4.3.2.1.170 | 51.5d | 0d | SSH-Construction Manhours [41474.1 h] | 273,000 |  |
| 1.4.3.2.1.200 |  | Install 250mm thk prefabricated wall panel | 30d | 2012-02-22 | 2012-03-21 | 1.4.3.2.1.190 SS+25d | 95.75d | 0d | SSH-Construction Manhours [24000 h] | 690,000 |  |
| 1.4.3.2.1.210 |  | Install 250mm thk prefabricated wall panel, 150mm thkx650mm | 30d | 2012-03-17 | 2012-04-14 | 1.4.3.2.1.200 SS+25d | 95.75d | 0d | SSH-Construction Manhours [24000 h] | 795,000 |  |
| 1.4.3.2.1.220 |  | Install expanded wire mesh on frame as per SSD/20 | 30d | 2012-04-04 | 2012-05-02 | 1.4.3.2.1.210 SS+20d, 1.4.3.2.1.230 | 95.75d | 29d | SSH-Construction Manhours [41474.1 h] | 148,500 |  |

| ID | WBS | Activity | Duration | Start | Finish | Predecessors | Total float | Free float | Resources | Cost | QTY |
| --- | --- | --- | --- | --- | --- | --- | --- | --- | --- | --- | --- |
|  | 3 | **Architectural Works** |  | 2012-01-30 | 2012-08-14 |  |  |  |  |  |  |
|  | 1 | **Masonry work** |  | 2012-01-30 | 2012-04-02 |  |  |  |  |  |  |
| 1.4.3.2.1.310 |  | Install 200mm thk CMU blocks | 37.5d | 2012-01-30 | 2012-03-05 | 1.4.3.2.1.190 SS | 51.5d | 0d | SSH-Construction Manhours [38343.2 h] | 425,000 |  |
| 1.4.3.2.1.320 |  | Install 50mm thk morter plastering work | 37.5d | 2012-02-27 | 2012-04-02 | 1.4.3.2.1.310 SS+30d | 169.25d | 0d | SSH-Construction Manhours [28757.4 h] | 354,100 | 0.0174284069 |
|  | 2 | **Floor Finishing work** |  | 2012-05-02 | 2012-06-19 |  |  |  |  |  |  |
| 1.4.3.2.1.330 |  | Install ceramic tiling works | 20d | 2012-05-02 | 2012-05-20 | 1.4.3.2.1.380 SS | 66.75d | 0d | SSH-Construction Manhours [14400 h] | 51,000 |  |
| 1.4.3.2.1.340 |  | Install cement toping works | 20d | 2012-05-12 | 2012-05-29 | 1.4.3.2.1.330 SS+10d | 66.75d | 0d | SSH-Construction Manhours [14400 h] | 50,000 |  |
| 1.4.3.2.1.350 |  | Install vinyl tiling works | 20d | 2012-05-21 | 2012-06-07 | 1.4.3.2.1.340 SS+10d | 66.75d | 0d | SSH-Construction Manhours [14400 h] | 40,800 |  |
| 1.4.3.2.1.360 |  | Install APCS-12 painting works | 20d | 2012-05-30 | 2012-06-17 | 1.4.3.2.1.350 SS+10d | 66.75d | 0d | SSH-Construction Manhours [12800 h] | 35,250 |  |
| 1.4.3.2.1.370 |  | Install accs floor system | 12d | 2012-06-09 | 2012-06-19 | 1.4.3.2.1.360 SS+10d | 66.75d | 0d | SSH-Construction Manhours [7680 h] | 205,000 | 0.0516944272 |
|  | 3 | **Wall Finishing work** |  | 2012-05-02 | 2012-06-12 |  |  |  |  |  |  |
| 1.4.3.2.1.380 |  | Install dry wall partition works | 25d | 2012-05-02 | 2012-05-24 | 1.4.3.2.1.180, 1.4.3.2.1.220 SS, 1.3.1.5.430, 1.3.1.5.330 | 66.75d | 0d | SSH-Construction Manhours [18000 h] | 117,750 |  |
| 1.4.3.2.1.390 |  | Install ceramic wall tiling works | 25d | 2012-05-12 | 2012-06-03 | 1.4.3.2.1.380 SS+10d | 98.75d | 0d | SSH-Construction Manhours [18000 h] | 43,500 |  |
| 1.4.3.2.1.400 |  | Install wall painting works | 25d | 2012-05-21 | 2012-06-12 | 1.4.3.2.1.390 SS+10d | 98.75d | 27d | SSH-Construction Manhours [16000 h] | 90,750 | 0.0179453512 |
|  | 4 | **Ceiling Finishing work** |  | 2012-06-19 | 2012-07-31 |  |  |  |  |  |  |
| 1.4.3.2.1.410 |  | Install acoustical celing works | 25d | 2012-06-19 | 2012-07-12 | 1.4.3.2.1.400 SS, 1.4.3.2.1.370, 1.3.1.5.230 | 66.75d | 0d | SSH-Construction Manhours [16000 h] | 40,925 |  |
| 1.4.3.2.1.420 |  | Install gypsum board celing works | 25d | 2012-06-28 | 2012-07-22 | 1.4.3.2.1.410 SS+10d | 81.75d | 0d | SSH-Construction Manhours [12000 h] | 36,300 |  |
| 1.4.3.2.1.430 |  | Install ceiling painting works | 25d | 2012-07-08 | 2012-07-31 | 1.4.3.2.1.420 SS+10d, 1.4.3.2.1.400 | 81.75d | 15d | SSH-Construction Manhours [12000 h] | 52,050 | 0.0065134978 |
|  | 5 | **Roof Finishing work** |  | 2012-07-03 | 2012-08-09 |  |  |  |  |  |  |
| 1.4.3.2.1.440 |  | Install roof water proofing system | 25d | 2012-07-03 | 2012-07-26 | 1.4.3.2.1.410 SS+15d | 66.75d | 0d | SSH-Construction Manhours [10000 h] | 195,000 |  |
| 1.4.3.2.1.450 |  | Install roof painting works | 20d | 2012-07-22 | 2012-08-09 | 1.4.3.2.1.440 SS+20d | 66.75d | 0d | SSH-Construction Manhours [8000 h] | 52,400 | 0.0066168867 |
|  | 6 | **Doors & Windows** |  | 2012-07-22 | 2012-08-14 |  |  |  |  |  |  |
| 1.4.3.2.1.460 |  | Install doors & windows with frames | 25d | 2012-07-22 | 2012-08-14 | 1.4.3.2.1.450 SS, 1.4.3.2.1.430 SS, 1.4.3.2.1.030 | 66.75d | 0d | SSH-Construction Manhours [10000 h] | 119,600 | 0.0264675467 |
|  | 4 | **Plumbing Works** |  | 2012-04-14 | 2012-06-09 |  |  |  |  |  |  |
| 1.4.3.2.1.510 |  | Install plumbing conduits & fittings | 35d | 2012-04-14 | 2012-05-16 | 1.4.3.2.1.210 | 144d | 0d | SSH-Construction Manhours [16800 h] | 110,000 |  |
| 1.4.3.2.1.520 |  | Install plumbing fixtures | 30d | 2012-05-02 | 2012-05-30 | 1.4.3.2.1.510 SS+20d | 144d | 0d | SSH-Construction Manhours [14400 h] | 45,500 |  |
| 1.4.3.2.1.530 |  | Install countertop w/built in lavatory | 20d | 2012-05-21 | 2012-06-09 | 1.4.3.2.1.520 SS+20d | 144d | 66.75d | SSH-Construction Manhours [12800 h] | 39,500 | 0.0028062689 |

| ID | WBS | Activity | Duration | Start | Finish | Predecessors | Total float | Free float | Resources | Cost | QTY |
| --- | --- | --- | --- | --- | --- | --- | --- | --- | --- | --- | --- |
|  | 5 | **Mechanical / HVAC Works** |  | 2012-04-23 | 2012-08-28 |  |  |  |  |  |  |
| 1.4.3.2.1.630 |  | Install ducting system | 45d | 2012-04-23 | 2012-06-03 | 1.4.3.2.1.310, 1.3.5.4.9.030, 1.3.5.4.10.030, 1.3.5.4.7.030 | 77.25d | 0d | SSH-Construction Manhours [28757.4 h] | 150,000 |  |
| 1.4.3.2.1.640 |  | Install air & outlets accs | 25d | 2012-05-21 | 2012-06-12 | 1.4.3.2.1.630 SS+30d | 77.25d | 0d | SSH-Construction Manhours [16000 h] | 85,000 |  |
| 1.4.3.2.1.650 |  | Install fire / volume dampers | 25d | 2012-05-30 | 2012-06-21 | 1.4.3.2.1.640 SS+10d | 77.25d | 0d | SSH-Construction Manhours [16000 h] | 85,000 |  |
| 1.4.3.2.1.660 |  | Install sandtrap louvers | 15d | 2012-06-10 | 2012-06-24 | 1.4.3.2.1.650 SS+12d | 77.25d | 0d | SSH-Construction Manhours [9600 h] | 16,200 |  |
| 1.4.3.2.1.670 |  | Install exhaust fan | 10d | 2012-06-19 | 2012-06-28 | 1.4.3.2.1.660 SS+10d, 1.3.5.4.10.060 | 77.25d | 0d | SSH-Construction Manhours [4800 h] | 15,000 |  |
| 1.4.3.2.1.680 |  | Install fire protection system | 10d | 2012-06-25 | 2012-07-04 | 1.4.3.2.1.670 SS+6d | 77.25d | 0d | SSH-Construction Manhours [3200 h] | 75,500 |  |
| 1.4.3.2.1.610 |  | Install ACCU equipments | 25d | 2012-07-01 | 2012-07-24 | 1.4.3.2.1.680 SS+6d | 77.25d | 0d | SSH-Construction Manhours [18000 h] | 850,000 |  |
| 1.4.3.2.1.685 |  | Install fire extinguishers | 10d | 2012-07-02 | 2012-07-11 | 1.4.3.2.1.680 SS+8d | 109d | 31.75d | SSH-Construction Manhours [3200 h] | 15,500 | 0.0045786493 |
| 1.4.3.2.1.620 |  | Install AHU equipments | 25d | 2012-07-18 | 2012-08-11 | 1.4.3.2.1.610 SS+18.75d | 77.25d | 0d | SSH-Construction Manhours [18000 h] | 510,000 |  |
| 1.4.3.2.1.690 |  | Testing & balancing of HVAC system | 18.75d | 2012-08-11 | 2012-08-28 | 1.4.3.2.1.620, 1.4.3.2.1.685 SS+10d, 1.4.3.2.1.530 | 77.25d | 25.75d | SSH-Construction Manhours [9000 h] | 15,000 |  |
|  | 6 | **Electrical Works** |  | 2012-03-17 | 2012-07-26 |  |  |  |  |  |  |
| 1.4.3.2.1.710 |  | Install electrical conduits / fittings | 30d | 2012-03-17 | 2012-04-14 | 1.4.3.2.1.310 FS+12.5d, 1.3.3.2.2.030 | 51.5d | 0d | SSH-Construction Manhours [19171.6 h] | 61,030 |  |
| 1.4.3.2.1.720 |  | Install cables / wires | 25d | 2012-03-26 | 2012-04-18 | 1.4.3.2.1.710 SS+10d | 121.75d | 0d | SSH-Construction Manhours [16000 h] | 25,000 |  |
| 1.4.3.2.1.730 |  | Install lighting fixtures | 25d | 2012-04-09 | 2012-05-02 | 1.4.3.2.1.720 SS+15d | 121.75d | 0d | SSH-Construction Manhours [10000 h] | 160,000 |  |
| 1.4.3.2.1.740 |  | Install panelboards | 10d | 2012-04-23 | 2012-05-02 | 1.4.3.2.1.730 SS+15d | 121.75d | 0d | SSH-Construction Manhours [4000 h] | 15,000 |  |
| 1.4.3.2.1.750 |  | Install lighting control panel | 10d | 2012-04-28 | 2012-05-07 | 1.4.3.2.1.740 SS+5d | 121.75d | 0d | SSH-Construction Manhours [4000 h] | 6,000 |  |
| 1.4.3.2.1.760 |  | Install annunciator DC distribution panel | 15d | 2012-05-02 | 2012-05-16 | 1.4.3.2.1.750 SS+5d | 121.75d | 0d | SSH-Construction Manhours [8400 h] | 70,000 |  |
| 1.4.3.2.1.770 |  | Install battery bank / battery charger/UPS | 15d | 2012-05-07 | 2012-05-21 | 1.4.3.2.1.760 SS+5d, 1.3.2.7.6.130 | 121.75d | 0d | SSH-Construction Manhours [8400 h] | 400,000 |  |
| 1.4.3.2.1.780 |  | Install inventor | 10d | 2012-05-12 | 2012-05-21 | 1.4.3.2.1.770 SS+5d | 121.75d | 0d | SSH-Construction Manhours [4800 h] | 870,000 |  |
| 1.4.3.2.1.790 |  | Install inventor distribution panel | 10d | 2012-05-16 | 2012-05-26 | 1.4.3.2.1.780 SS+5d | 121.75d | 0d | SSH-Construction Manhours [4800 h] | 65,000 |  |
| 1.4.3.2.1.800 |  | Install disconnect switches | 15d | 2012-05-21 | 2012-06-04 | 1.4.3.2.1.790 SS+5d | 121.75d | 0d | SSH-Construction Manhours [7200 h] | 5,200 |  |
| 1.4.3.2.1.810 |  | Install FAS-Fire alarm system & FACP with detection sytem | 15d | 2012-05-26 | 2012-06-09 | 1.4.3.2.1.800 SS+5d | 121.75d | 0d | SSH-Construction Manhours [7200 h] | 40,000 |  |
| 1.4.3.2.1.820 |  | Install grounding system | 15d | 2012-05-30 | 2012-06-13 | 1.4.3.2.1.810 SS+5d | 121.75d | 0d | SSH-Construction Manhours [7200 h] | 45,000 |  |
| 1.4.3.2.1.830 |  | Install circuit breaker | 15d | 2012-06-04 | 2012-06-18 | 1.4.3.2.1.820 SS+5d | 121.75d | 0d | SSH-Construction Manhours [7200 h] | 150,000 |  |
| 1.4.3.2.1.840 |  | Install ATS | 15d | 2012-06-09 | 2012-06-23 | 1.4.3.2.1.830 SS+5d | 121.75d | 0d | SSH-Construction Manhours [7200 h] | 260,000 |  |
| 1.4.3.2.1.850 |  | Install rectifier | 15d | 2012-06-13 | 2012-06-27 | 1.4.3.2.1.840 SS+5d | 121.75d | 0d | SSH-Construction Manhours [7200 h] | 590,000 |  |
| 1.4.3.2.1.860 |  | Install 500kva generator | 15d | 2012-06-18 | 2012-07-02 | 1.4.3.2.1.850 SS+5d | 121.75d | 0d | SSH-Construction Manhours [7200 h] | 900,000 |  |
| 1.4.3.2.1.870 |  | Install 300kva, 13.8kv XFR | 15d | 2012-06-23 | 2012-07-07 | 1.4.3.2.1.860 SS+5d | 121.75d | 0d | SSH-Construction Manhours [6000 h] | 80,000 |  |
| 1.4.3.2.1.880 |  | Install switchboards | 15d | 2012-06-27 | 2012-07-11 | 1.4.3.2.1.870 SS+5d | 121.75d | 0d | SSH-Construction Manhours [4800 h] | 145,000 |  |
| 1.4.3.2.1.890 |  | Testing/commissioning electrical system | 25d | 2012-07-03 | 2012-07-26 | 1.4.3.2.1.880 SS+6d | 121.75d | 70.25d | SSH-Construction Manhours [6000 h] | 250,000 | 0.0738491818 |

| ID | WBS | Activity | Duration | Start | Finish | Predecessors | Total float | Free float | Resources | Cost | QTY |
| --- | --- | --- | --- | --- | --- | --- | --- | --- | --- | --- | --- |
|  | 7 | **Communication Works at Exch Bldg #1** |  | 2012-04-14 | 2012-06-27 |  |  |  |  |  |  |
| 1.4.3.2.1.910 |  | Install comm conduits / fittings | 45d | 2012-04-14 | 2012-05-26 | 1.4.3.2.1.710, 1.3.3.2.1.130 | 51.5d | 0d | SSH-Construction Manhours [28757.4 h] | 15,000 |  |
| 1.4.3.2.1.920 |  | Install comm vault / accs | 25d | 2012-05-12 | 2012-06-04 | 1.4.3.2.1.910 SS+30d | 51.5d | 0d | SSH-Construction Manhours [24000 h] | 260,000 |  |
| 1.4.3.2.1.930 |  | Install comm equipments / accs | 25d | 2012-05-26 | 2012-06-18 | 1.4.3.2.1.920 SS+15d, 1.3.3.2.2.130 | 51.5d | 0d | SSH-Construction Manhours [16000 h] | 5,000 |  |
| 1.4.3.2.1.940 |  | Install comm outlets / accs | 25d | 2012-06-04 | 2012-06-27 | 1.4.3.2.1.930 SS+10d | 51.5d | 0d | SSH-Construction Manhours [20000 h] | 3,000 | 0.0008861902 |
|  | 8 | **Communication Works at Exch Bldg #1 with existing network** |  | 2012-06-27 | 2012-09-05 |  |  |  |  |  |  |
| 1.4.3.2.1.1010 |  | Install comm equip to connect with existing exch bldg | 75d | 2012-06-27 | 2012-09-05 | 1.4.3.2.1.940, 1.3.3.3.030 | 51.5d | 0d | SSH-Construction Manhours [28800 h] | 220,000 | 0.06498728 |
|  | 9 | **Communication Works at Exch Bldg #1 with security HQ bldg** |  | 2012-07-09 | 2012-09-20 |  |  |  |  |  |  |
| 1.4.3.2.1.1110 |  | Install comm equip to connect with security HQ | 78.75d | 2012-07-09 | 2012-09-20 | 1.4.3.2.1.1010 SS+12.5d | 51.5d | 0d | SSH-Construction Manhours [28800 h] | 65,000 | 0.0192007873 |
|  | 10 | **Communication Works at Exch Bldg #1 with exst bsns data center** |  | 2012-08-14 | 2012-09-06 |  |  |  |  |  |  |
| 1.4.3.2.1.1210 |  | Install comm equip to connect with exst business center | 25d | 2012-08-14 | 2012-09-06 | 1.4.3.2.1.1110 SS+10d, 1.4.3.2.1.460 | 66.75d | 15.25d | SSH-Construction Manhours [8000 h] | 95,000 | 0.0280626891 |
|  | 11 | **SACS System** |  | 2012-08-14 | 2012-10-04 |  |  |  |  |  |  |
| 1.4.3.2.1.1310 |  | Install access switches | 45d | 2012-08-14 | 2012-09-25 | 1.4.3.2.1.1010 SS, 1.3.3.3.130 | 69d | 0d | SSH-Construction Manhours [27649.4 h] | 180,000 |  |
| 1.4.3.2.1.1320 |  | Install miscellaneous items | 45d | 2012-08-23 | 2012-10-04 | 1.4.3.2.1.1310 SS+10d, 1.4.3.2.1.1480, 1.4.3.2.1.1520 | 69d | 17.5d | SSH-Construction Manhours [27649.4 h] | 30,000 |  |
| 1.4.3.2.1.1330 |  | Testing / commissioning & Energize SACS system | 10d | 2012-09-20 | 2012-09-30 | 1.4.3.2.1.1320 SS+12.5d, 1.4.2.8.1.110 SS+12.5d, 1.4.3.2.1.1010, 1.4.3.2.1.1110 | 51.5d | 0d | SSH-Construction Manhours [2400 h] | 5,000 |  |
| 1.4.3.2.1.1340 |  | Energize SACS System & Communication Bldg | 10d | 2012-09-20 | 2012-09-30 | 1.4.3.2.1.1330 SS, 1.4.3.2.1.1010, 1.4.3.2.1.1110, 1.4.3.2.1.1210, 1.4.3.2.1.690, 1.4.3.1.1.570, M2.10 | 51.5d | 0d | SSH-Construction Manhours [2400 h] | 5,000 | 0.0014769836 |
|  | 12 | **Pavement / Parking / Signs / Markings** |  | 2012-02-27 | 2012-04-30 |  |  |  |  |  |  |
| 1.4.3.2.1.1410 |  | Install gravel pavement | 30d | 2012-02-27 | 2012-03-26 | 1.4.3.2.1.320 SS, 1.4.3.2.1.030 | 169.25d | 0d | SSH-Construction Manhours [12000.7 h] | 40,600 |  |
| 1.4.3.2.1.1420 |  | Install 150mm thk concrete pavement | 30d | 2012-03-06 | 2012-04-03 | 1.4.3.2.1.1410 SS+8d | 169.25d | 0d | SSH-Construction Manhours [16800 h] | 679,650 |  |
| 1.4.3.2.1.1430 |  | Install 500mm thk general fill | 30d | 2012-03-13 | 2012-04-10 | 1.4.3.2.1.1420 SS+8d | 169.25d | 0d | SSH-Construction Manhours [12000 h] | 73,875 |  |
| 1.4.3.2.1.1440 |  | Install 200mm thk aggregate base coarse | 30d | 2012-03-21 | 2012-04-17 | 1.4.3.2.1.1430 SS+8d | 169.25d | 0d | SSH-Construction Manhours [19200 h] | 76,830 |  |
| 1.4.3.2.1.1450 |  | Install 120mm thk asphalt concrete pavement | 25d | 2012-03-28 | 2012-04-21 | 1.4.3.2.1.1440 SS+8d | 169.25d | 0d | SSH-Construction Manhours [16000 h] | 236,400 |  |
| 1.4.3.2.1.1460 |  | Install shaded parking space | 25d | 2012-04-04 | 2012-04-28 | 1.4.3.2.1.1450 SS+8d | 193.5d | 0d | SSH-Construction Manhours [12800 h] | 48,600 |  |
| 1.4.3.2.1.1470 |  | Install road / park markings | 20d | 2012-04-04 | 2012-04-23 | 1.4.3.2.1.1460 SS | 193.5d | 0d | SSH-Construction Manhours [12800 h] | 3,000 |  |
| 1.4.3.2.1.1480 |  | Install road / park signs | 18.75d | 2012-04-12 | 2012-04-30 | 1.4.3.2.1.1470 SS+8d | 193.5d | 124.5d | SSH-Construction Manhours [7680 h] | 4,320 | 0.0012761139 |

| ID | WBS | Activity | Duration | Start | Finish | Predecessors | Total float | Free float | Resources | Cost | QTY |
| --- | --- | --- | --- | --- | --- | --- | --- | --- | --- | --- | --- |
|  | 13 | **Perimeter Fence System** |  | 2012-04-01 | 2012-05-22 |  |  |  |  |  |  |
| 1.4.3.2.1.1510 |  | Install perimeter fence type SSD-1 | 45d | 2012-04-01 | 2012-05-13 | 1.4.3.2.1.1450 SS+4d | 169.25d | 0d | SSH-Construction Manhours [36000 h] | 202,500 |  |
| 1.4.3.2.1.1520 |  | Install perimeter gate SSD-1, 10.5m widex2 leaf | 25d | 2012-04-29 | 2012-05-22 | 1.4.3.2.1.1510 SS+30d | 169.25d | 100.25d | SSH-Construction Manhours [20000 h] | 18,500 | 0.0054648395 |
|  | 3 | **Toilet Facilities (3 nos)** |  | 2012-03-17 | 2012-11-20 |  |  |  |  |  |  |
|  | 1 | **Toilet # 1** |  | 2012-03-17 | 2012-11-04 |  |  |  |  |  |  |
|  | 1 | **Civil works** |  | 2012-03-17 | 2012-08-14 |  |  |  |  |  |  |
| 1.4.3.3.1.1.010 |  | Excavation leveling & compaction for toilet # 1 bldg fdns | 10d | 2012-03-17 | 2012-03-25 | 1.2.6.200 FS+237.5d, 1.4.3.1.1.140 SS | 37.75d | 0d | SSH-Construction Manhours [4800 h]; Excavator [80 h]; Dump Truck [80 h] | 1,250 |  |
| 1.4.3.3.1.1.020 |  | Backfilling/compation | 12.5d | 2012-08-02 | 2012-08-14 | 1.4.3.3.1.1.070 | 207.75d | 65.25d | SSH-Construction Manhours [3000 h]; Dump Truck [100 h]; Compactor [100 h] | 1,225 | 0.000361861 |
|  | 2 | **Structural works** |  | 2012-03-21 | 2012-08-13 |  |  |  |  |  |  |
| 1.4.3.3.1.1.030 |  | Install lean concrete for reinforced fdns for toilet bldg | 18.75d | 2012-03-21 | 2012-04-08 | 1.4.3.3.1.1.010 SS+6d | 122d | 0d | SSH-Construction Manhours [10500 h] | 1,050 |  |
| 1.4.3.3.1.1.040 |  | Install reinforced fdns for toilet bldg | 31.25d | 2012-04-19 | 2012-05-19 | 1.4.3.3.1.1.030 SS+31.25d | 139.75d | 0d | SSH-Construction Manhours [17500 h] | 28,600 |  |
| 1.4.3.3.1.1.050 |  | Install reinforced columns | 45d | 2012-05-19 | 2012-06-30 | 1.4.3.3.1.1.040 SS+31.25d | 139.75d | 0d | SSH-Construction Manhours [21600 h] | 18,000 |  |
| 1.4.3.3.1.1.060 |  | Install reinforced roof beams | 45d | 2012-06-17 | 2012-07-29 | 1.4.3.3.1.1.050 SS+31.25d | 139.75d | 0d | SSH-Construction Manhours [21600 h] | 18,000 |  |
| 1.4.3.3.1.1.070 |  | Install reinforced roof slab /paraphet | 35d | 2012-07-01 | 2012-08-02 | 1.4.3.3.1.1.060 SS+15d | 139.75d | 0d | SSH-Construction Manhours [16800 h] | 26,000 |  |
| 1.4.3.3.1.1.080 |  | Install reinforced slab on grade | 31.25d | 2012-07-15 | 2012-08-13 | 1.4.3.3.1.1.070 SS+15d | 172.5d | 30d | SSH-Construction Manhours [20000 h] | 14,720 | 0.0043482398 |
|  | 3 | **Architectural works** |  | 2012-08-02 | 2012-11-04 |  |  |  |  |  |  |
|  | 1 | **Masonry** |  | 2012-08-02 | 2012-09-10 |  |  |  |  |  |  |
| 1.4.3.3.1.1.090 |  | Install 200mm thk CMU blocks | 31.25d | 2012-08-02 | 2012-09-01 | 1.4.3.3.1.1.070 | 139.75d | 0d | SSH-Construction Manhours [24000 h] | 14,915 |  |
| 1.4.3.3.1.1.100 |  | Install 50 mm thk mortar plastering work | 31.25d | 2012-08-12 | 2012-09-10 | 1.4.3.3.1.1.090 SS+10d | 142.5d | 0d | SSH-Construction Manhours [22500 h] | 37,100 | 0.0109592186 |
|  | 2 | **Floor Finishing** |  | 2012-09-24 | 2012-10-31 |  |  |  |  |  |  |
| 1.4.3.3.1.1.110 |  | Install cement toping work | 31.25d | 2012-09-24 | 2012-10-22 | 1.4.3.3.1.1.140 SS | 142.5d | 0d | SSH-Construction Manhours [15000 h] | 5,500 |  |
| 1.4.3.3.1.1.120 |  | Install cermaic tiling work | 31.25d | 2012-10-03 | 2012-10-31 | 1.4.3.3.1.1.110 SS+10d, 1.4.3.3.1.1.150 SS, 1.4.3.3.1.1.020 SS | 142.5d | 62.5d | SSH-Construction Manhours [15000 h] | 11,000 | 0.003249364 |
|  | 3 | **Wall Finishing** |  | 2012-09-17 | 2012-10-29 |  |  |  |  |  |  |
| 1.4.3.3.1.1.130 |  | Install phenolic toilet partition | 31.25d | 2012-09-17 | 2012-10-16 | 1.4.3.3.1.1.170 SS | 142.5d | 0d | SSH-Construction Manhours [10000 h] | 70,000 |  |
| 1.4.3.3.1.1.140 |  | Install ceramic tiling work | 31.25d | 2012-09-24 | 2012-10-22 | 1.4.3.3.1.1.130 SS+7d | 142.5d | 0d | SSH-Construction Manhours [10000 h] | 25,000 |  |
| 1.4.3.3.1.1.150 |  | Install textured painted work on CMU wall | 31.25d | 2012-09-30 | 2012-10-29 | 1.4.3.3.1.1.140 SS+7d | 145.5d | 3d | SSH-Construction Manhours [12500 h] | 33,750 | 0.0099696395 |

| ID | WBS | Activity | Duration | Start | Finish | Predecessors | Total float | Free float | Resources | Cost | QTY |
| --- | --- | --- | --- | --- | --- | --- | --- | --- | --- | --- | --- |
|  | 4 | **Ceiling Finihsing** |  | 2012-09-10 | 2012-10-16 |  |  |  |  |  |  |
| 1.4.3.3.1.1.160 |  | Install gypsum board ceiling system | 25d | 2012-09-10 | 2012-10-03 | 1.4.3.3.1.1.100, 1.4.3.3.1.1.080 | 142.5d | 0d | SSH-Construction Manhours [10000 h] | 5,400 |  |
| 1.4.3.3.1.1.170 |  | Install painting work | 25d | 2012-09-17 | 2012-10-10 | 1.4.3.3.1.1.160 SS+7d | 142.5d | 0d | SSH-Construction Manhours [8000 h] | 4,200 |  |
| 1.4.3.3.1.1.180 |  | Install roof water proofing system & scrupper | 25d | 2012-09-24 | 2012-10-16 | 1.4.3.3.1.1.170 SS+7d | 158.75d | 19d | SSH-Construction Manhours [8000 h] | 30,000 | 0.0088619018 |
|  | 5 | **Doors / Windows / Toilet Accs** |  | 2012-10-02 | 2012-11-04 |  |  |  |  |  |  |
| 1.4.3.3.1.1.190 |  | Install doors & windows | 25d | 2012-10-02 | 2012-10-25 | 1.4.3.3.1.1.290 | 139.75d | 0d | SSH-Construction Manhours [6400 h] | 18,000 |  |
| 1.4.3.3.1.1.200 |  | Install toilet fixtures & accs | 25d | 2012-10-07 | 2012-10-30 | 1.4.3.3.1.1.190 SS+5d | 139.75d | 0d | SSH-Construction Manhours [6400 h] | 180,000 |  |
| 1.4.3.3.1.1.210 |  | Install cabinet & counter top | 25d | 2012-10-11 | 2012-11-04 | 1.4.3.3.1.1.200 SS+5d, 1.4.3.3.1.1.180 SS | 139.75d | 59.75d | SSH-Construction Manhours [6400 h] | 165,000 | 0.04874046 |
|  | 4 | **Electrical works** |  | 2012-08-02 | 2012-09-09 |  |  |  |  |  |  |
| 1.4.3.3.1.1.220 |  | Install electric conduits / fittings | 25d | 2012-08-02 | 2012-08-26 | 1.4.3.3.1.1.090 SS | 174d | 0d | SSH-Construction Manhours [3840 h] | 18,190 |  |
| 1.4.3.3.1.1.230 |  | Install cables / wires | 25d | 2012-08-06 | 2012-08-29 | 1.4.3.3.1.1.220 SS+3d | 174d | 0d | SSH-Construction Manhours [3840 h] | 125,000 |  |
| 1.4.3.3.1.1.240 |  | Install lighting fixtures | 25d | 2012-08-08 | 2012-09-01 | 1.4.3.3.1.1.230 SS+3d | 174d | 0d | SSH-Construction Manhours [3840 h] | 35,000 |  |
| 1.4.3.3.1.1.250 |  | Install panelboards | 25d | 2012-08-12 | 2012-09-03 | 1.4.3.3.1.1.240 SS+3d | 174d | 0d | SSH-Construction Manhours [4000 h] | 5,000 |  |
| 1.4.3.3.1.1.255 |  | Install Lighting control panel | 25d | 2012-08-13 | 2012-09-05 | 1.4.3.3.1.1.250 SS+2d | 174d | 0d | SSH-Construction Manhours [4000 h] | 5,250 | 0.0015508328 |
| 1.4.3.3.1.1.260 |  | Install disconnect switches | 25d | 2012-08-15 | 2012-09-08 | 1.4.3.3.1.1.250 SS+2d, 1.4.3.3.1.1.255 SS+2d | 174d | 0d | SSH-Construction Manhours [4000 h] | 350 |  |
| 1.4.3.3.1.1.270 |  | Install grounding system | 25d | 2012-08-16 | 2012-09-09 | 1.4.3.3.1.1.260 SS+2d | 174d | 24.25d | SSH-Construction Manhours [4000 h] | 7,500 |  |
|  | 5 | **Water Supply System** |  | 2012-09-01 | 2012-09-24 |  |  |  |  |  |  |
| 1.4.3.3.1.1.280 |  | Install water supply system | 25d | 2012-09-01 | 2012-09-24 | 1.4.3.3.1.1.090 | 139.75d | 0d | SSH-Construction Manhours [6000 h] | 30,000 | 0.0088619018 |
|  | 6 | **Sewer System** |  | 2012-09-09 | 2012-10-02 |  |  |  |  |  |  |
| 1.4.3.3.1.1.290 |  | Install sewer system | 25d | 2012-09-09 | 2012-10-02 | 1.4.3.3.1.1.280 SS+8d | 139.75d | 0d | SSH-Construction Manhours [6000 h] | 35,000 | 0.0103388854 |
|  | 7 | **HVAC System** |  | 2012-10-02 | 2012-10-25 |  |  |  |  |  |  |
| 1.4.3.3.1.1.300 |  | Install HVAC system | 25d | 2012-10-02 | 2012-10-25 | 1.4.3.3.1.1.290, 1.4.3.3.1.1.270 | 149.75d | 69.75d | SSH-Construction Manhours [8000 h] | 30,000 | 0.0088619018 |
|  | 8 | **Toilet # 2** |  | 2012-04-04 | 2012-11-04 |  |  |  |  |  |  |
|  | 1 | **Civil works** |  | 2012-04-04 | 2012-08-06 |  |  |  |  |  |  |
| 1.4.3.3.1.2.010 |  | Excavation leveling & compaction for toilet # 2 bldg fdns | 10d | 2012-04-04 | 2012-04-14 | 1.4.3.3.1.1.030 SS+15d | 122d | 0d | SSH-Construction Manhours [15000 h]; Excavator [80 h]; Dump Truck [80 h] | 1,250 |  |
| 1.4.3.3.1.2.020 |  | Backfilling/compation | 12.5d | 2012-07-25 | 2012-08-06 | 1.4.3.3.1.2.070 | 210.5d | 71.5d | SSH-Construction Manhours [9000 h]; Dump Truck [100 h]; Compactor [100 h] | 1,225 | 0.000361861 |

| ID | WBS | Activity | Duration | Start | Finish | Predecessors | Total float | Free float | Resources | Cost | QTY |
| --- | --- | --- | --- | --- | --- | --- | --- | --- | --- | --- | --- |
|  | 2 | **Structural works** |  | 2012-04-10 | 2012-08-23 |  |  |  |  |  |  |
| 1.4.3.3.1.2.030 |  | Install lean concrete for reinforced fdns for toilet bldg | 18.75d | 2012-04-10 | 2012-04-28 | 1.4.3.3.1.2.010 SS+6d | 122d | 0d | SSH-Construction Manhours [12000 h] | 1,050 |  |
| 1.4.3.3.1.2.040 |  | Install reinforced fdns for toilet bldg | 31.25d | 2012-04-24 | 2012-05-23 | 1.4.3.3.1.2.030 SS+15d | 139d | 0d | SSH-Construction Manhours [17500 h] | 28,600 |  |
| 1.4.3.3.1.2.050 |  | Install reinforced columns | 45d | 2012-05-08 | 2012-06-19 | 1.4.3.3.1.2.040 SS+15d | 139d | 0d | SSH-Construction Manhours [21600 h] | 18,000 |  |
| 1.4.3.3.1.2.060 |  | Install reinforced roof beams | 50d | 2012-05-22 | 2012-07-08 | 1.4.3.3.1.2.050 SS+15d | 139d | 0d | SSH-Construction Manhours [24000 h] | 18,000 |  |
| 1.4.3.3.1.2.070 |  | Install reinforced roof slab /paraphet | 37.5d | 2012-06-20 | 2012-07-25 | 1.4.3.3.1.2.060 SS+31.25d | 139d | 0d | SSH-Construction Manhours [19171.6 h] | 26,000 |  |
| 1.4.3.3.1.2.080 |  | Install reinforced slab on grade | 37.5d | 2012-07-19 | 2012-08-23 | 1.4.3.3.1.2.070 SS+31.25d | 181.75d | 42.75d | SSH-Construction Manhours [12781.1 h] | 14,720 | 0.0043482398 |
|  | 3 | **Architectural works** |  | 2012-07-25 | 2012-11-04 |  |  |  |  |  |  |
|  | 1 | **Masonry** |  | 2012-07-25 | 2012-08-27 |  |  |  |  |  |  |
| 1.4.3.3.1.2.090 |  | Install 200mm thk CMU blocks | 25d | 2012-07-25 | 2012-08-18 | 1.4.3.3.1.2.070 | 139d | 0d | SSH-Construction Manhours [16000 h] | 14,915 |  |
| 1.4.3.3.1.2.100 |  | Install 50 mm thk mortar plastering work | 25d | 2012-08-04 | 2012-08-27 | 1.4.3.3.1.2.090 SS+10d | 139d | 0d | SSH-Construction Manhours [12000 h] | 37,100 | 0.0109592186 |
|  | 2 | **Floor Finishing** |  | 2012-10-02 | 2012-11-04 |  |  |  |  |  |  |
| 1.4.3.3.1.2.110 |  | Install cement toping work | 25d | 2012-10-02 | 2012-10-25 | 1.4.3.3.1.2.140 SS, 1.4.3.3.1.2.080 | 139d | 0d | SSH-Construction Manhours [12000 h] | 5,500 |  |
| 1.4.3.3.1.2.120 |  | Install cermaic tiling work | 25d | 2012-10-11 | 2012-11-04 | 1.4.3.3.1.2.110 SS+10d, 1.4.3.3.1.2.020, 1.4.3.3.1.2.150 SS | 139d | 59d | SSH-Construction Manhours [12000 h] | 11,000 | 0.003249364 |
|  | 3 | **Wall Finishing** |  | 2012-09-26 | 2012-11-01 |  |  |  |  |  |  |
| 1.4.3.3.1.2.130 |  | Install phenolic toilet partition | 25d | 2012-09-26 | 2012-10-20 | 1.4.3.3.1.2.170 | 139d | 0d | SSH-Construction Manhours [9600 h] | 70,000 |  |
| 1.4.3.3.1.2.140 |  | Install ceramic tiling work | 25d | 2012-10-02 | 2012-10-25 | 1.4.3.3.1.2.130 SS+7d | 139d | 0d | SSH-Construction Manhours [9600 h] | 25,000 |  |
| 1.4.3.3.1.2.150 |  | Install textured painted work on CMU wall | 25d | 2012-10-09 | 2012-11-01 | 1.4.3.3.1.2.140 SS+7d | 142d | 3d | SSH-Construction Manhours [9600 h] | 33,750 | 0.0099696395 |
|  | 4 | **Ceiling Finihsing** |  | 2012-08-27 | 2012-10-02 |  |  |  |  |  |  |
| 1.4.3.3.1.2.160 |  | Install gypsum board ceiling system | 25d | 2012-08-27 | 2012-09-19 | 1.4.3.3.1.2.100 | 139d | 0d | SSH-Construction Manhours [9600 h] | 5,400 |  |
| 1.4.3.3.1.2.170 |  | Install painting work | 25d | 2012-09-03 | 2012-09-26 | 1.4.3.3.1.2.160 SS+7d | 139d | 0d | SSH-Construction Manhours [9600 h] | 4,200 |  |
| 1.4.3.3.1.2.180 |  | Install roof water proofing system & scrupper | 25d | 2012-09-09 | 2012-10-02 | 1.4.3.3.1.2.170 SS+7d | 174d | 94d | SSH-Construction Manhours [9600 h] | 30,000 | 0.0088619018 |
|  | 5 | **Doors / Windows / Toilet Accs** |  | 2012-09-18 | 2012-10-20 |  |  |  |  |  |  |
| 1.4.3.3.1.2.190 |  | Install doors & windows | 25d | 2012-09-18 | 2012-10-10 | 1.4.3.3.1.2.290 | 155d | 0d | SSH-Construction Manhours [4000 h] | 18,000 |  |
| 1.4.3.3.1.2.200 |  | Install toilet fixtures & accs | 25d | 2012-09-23 | 2012-10-15 | 1.4.3.3.1.2.190 SS+5d | 155d | 0d | SSH-Construction Manhours [4000 h] | 180,000 |  |
| 1.4.3.3.1.2.210 |  | Install cabinet & counter top | 25d | 2012-09-27 | 2012-10-20 | 1.4.3.3.1.2.200 SS+5d | 155d | 75d | SSH-Construction Manhours [4000 h] | 165,000 | 0.04874046 |

| ID | WBS | Activity | Duration | Start | Finish | Predecessors | Total float | Free float | Resources | Cost | QTY |
| --- | --- | --- | --- | --- | --- | --- | --- | --- | --- | --- | --- |
|  | 4 | **Electrical works** |  | 2012-07-25 | 2012-09-01 |  |  |  |  |  |  |
| 1.4.3.3.1.2.220 |  | Install electric conduits / fittings | 25d | 2012-07-25 | 2012-08-18 | 1.4.3.3.1.2.090 SS | 183d | 0d | SSH-Construction Manhours [4000 h] | 18,190 |  |
| 1.4.3.3.1.2.230 |  | Install cables / wires | 25d | 2012-07-29 | 2012-08-20 | 1.4.3.3.1.2.220 SS+3d | 183d | 0d | SSH-Construction Manhours [4000 h] | 125,000 |  |
| 1.4.3.3.1.2.240 |  | Install lighting fixtures | 25d | 2012-07-31 | 2012-08-23 | 1.4.3.3.1.2.230 SS+3d | 183d | 0d | SSH-Construction Manhours [4000 h] | 35,000 |  |
| 1.4.3.3.1.2.250 |  | Install panelboards | 25d | 2012-08-02 | 2012-08-26 | 1.4.3.3.1.2.240 SS+3d | 183d | 0d | SSH-Construction Manhours [4000 h] | 5,000 |  |
| 1.4.3.3.1.2.255 |  | Install lighting control panel | 25d | 2012-08-05 | 2012-08-28 | 1.4.3.3.1.2.250 SS+2d | 183d | 0d | SSH-Construction Manhours [4000 h] | 5,250 | 0.0015508328 |
| 1.4.3.3.1.2.260 |  | Install disconnect switches | 25d | 2012-08-07 | 2012-08-29 | 1.4.3.3.1.2.250 SS+2d, 1.4.3.3.1.2.255 SS+2d | 183d | 0d | SSH-Construction Manhours [4000 h] | 350 |  |
| 1.4.3.3.1.2.270 |  | Install grounding system | 25d | 2012-08-08 | 2012-09-01 | 1.4.3.3.1.2.260 SS+2d | 183d | 18d | SSH-Construction Manhours [4000 h] | 7,500 |  |
|  | 5 | **Water Supply System** |  | 2012-08-18 | 2012-09-10 |  |  |  |  |  |  |
| 1.4.3.3.1.2.280 |  | Install water supply system | 25d | 2012-08-18 | 2012-09-10 | 1.4.3.3.1.2.090 | 155d | 0d | SSH-Construction Manhours [4792.91 h] | 30,000 | 0.0088619018 |
|  | 6 | **Sewer System** |  | 2012-08-26 | 2012-09-17 |  |  |  |  |  |  |
| 1.4.3.3.1.2.290 |  | Install sewer system | 25d | 2012-08-26 | 2012-09-17 | 1.4.3.3.1.2.280 SS+8d | 155d | 0d | SSH-Construction Manhours [4792.91 h] | 35,000 | 0.0103388854 |
|  | 7 | **HVAC System** |  | 2012-09-18 | 2012-10-10 |  |  |  |  |  |  |
| 1.4.3.3.1.2.300 |  | Install HVAC system | 25d | 2012-09-18 | 2012-10-10 | 1.4.3.3.1.2.290, 1.4.3.3.1.2.270 | 165d | 85d | SSH-Construction Manhours [3195.27 h] | 30,000 | 0.0088619018 |
|  | 2 | **Toilet # 3** |  | 2012-04-28 | 2012-11-20 |  |  |  |  |  |  |
|  | 1 | **Civil works** |  | 2012-04-28 | 2012-08-26 |  |  |  |  |  |  |
| 1.4.3.3.1.3.010 |  | Excavation leveling & compaction for toilet # 3 bldg fdns | 10d | 2012-04-28 | 2012-05-07 | 1.4.3.3.1.2.030 | 122d | 0d | SSH-Construction Manhours [4800 h]; Excavator [80 h]; Dump Truck [80 h] | 1,250 |  |
| 1.4.3.3.1.3.020 |  | Backfilling/compation | 12.5d | 2012-08-14 | 2012-08-26 | 1.4.3.3.1.3.070 | 189.5d | 67.5d | SSH-Construction Manhours [4000 h]; Dump Truck [100 h]; Compactor [100 h] | 1,225 | 0.000361861 |
|  | 2 | **Structural works** |  | 2012-05-03 | 2012-08-28 |  |  |  |  |  |  |
| 1.4.3.3.1.3.030 |  | Install lean concrete for reinforced fdns for toilet bldg | 18.75d | 2012-05-03 | 2012-05-21 | 1.4.3.3.1.3.010 SS+6d | 122d | 0d | SSH-Construction Manhours [7500 h] | 1,050 |  |
| 1.4.3.3.1.3.040 |  | Install reinforced fdns for toilet bldg | 31.25d | 2012-05-17 | 2012-06-16 | 1.4.3.3.1.3.030 SS+15d | 122d | 0d | SSH-Construction Manhours [17500 h] | 28,600 |  |
| 1.4.3.3.1.3.050 |  | Install reinforced columns | 37.5d | 2012-05-31 | 2012-07-05 | 1.4.3.3.1.3.040 SS+15d | 122d | 0d | SSH-Construction Manhours [18000 h] | 18,000 |  |
| 1.4.3.3.1.3.060 |  | Install reinforced roof beams | 37.5d | 2012-06-14 | 2012-07-19 | 1.4.3.3.1.3.050 SS+15d | 122d | 0d | SSH-Construction Manhours [18000 h] | 18,000 |  |
| 1.4.3.3.1.3.070 |  | Install reinforced roof slab /paraphet | 50d | 2012-06-28 | 2012-08-14 | 1.4.3.3.1.3.060 SS+15d | 122d | 0d | SSH-Construction Manhours [18213 h] | 26,000 |  |
| 1.4.3.3.1.3.080 |  | Install reinforced slab on grade | 50d | 2012-07-12 | 2012-08-28 | 1.4.3.3.1.3.070 SS+15d | 187d | 65d | SSH-Construction Manhours [12142 h] | 14,720 | 0.0043482398 |

| ID | WBS | Activity | Duration | Start | Finish | Predecessors | Total float | Free float | Resources | Cost | QTY |
| --- | --- | --- | --- | --- | --- | --- | --- | --- | --- | --- | --- |
|  | 3 | **Architectural works** |  | 2012-08-14 | 2012-11-20 |  |  |  |  |  |  |
|  | 1 | **Masonry** |  | 2012-08-14 | 2012-09-16 |  |  |  |  |  |  |
| 1.4.3.3.1.3.090 |  | Install 200mm thk CMU blocks | 25d | 2012-08-14 | 2012-09-06 | 1.4.3.3.1.3.070 | 122d | 0d | SSH-Construction Manhours [12781.1 h] | 14,915 |  |
| 1.4.3.3.1.3.100 |  | Install 50 mm thk mortar plastering work | 25d | 2012-08-23 | 2012-09-16 | 1.4.3.3.1.3.090 SS+10d | 122d | 0d | SSH-Construction Manhours [9585.81 h] | 37,100 | 0.0109592186 |
|  | 2 | **Floor Finishing** |  | 2012-10-25 | 2012-11-20 |  |  |  |  |  |  |
| 1.4.3.3.1.3.110 |  | Install cement toping work | 25d | 2012-10-25 | 2012-11-17 | 1.4.3.3.1.3.140 SS+3d | 122d | 0d | SSH-Construction Manhours [30000 h] | 5,500 |  |
| 1.4.3.3.1.3.120 |  | Install ceramic tiling work | 25d | 2012-10-28 | 2012-11-20 | 1.4.3.3.1.3.110 SS+3d, 1.4.3.3.1.3.020, 1.4.3.3.1.3.080 | 122d | 42d | SSH-Construction Manhours [30000 h] | 11,000 | 0.003249364 |
|  | 3 | **Wall Finishing** |  | 2012-10-16 | 2012-11-20 |  |  |  |  |  |  |
| 1.4.3.3.1.3.130 |  | Install phenolic toilet partition | 25d | 2012-10-16 | 2012-11-07 | 1.4.3.3.1.3.170 | 122d | 0d | SSH-Construction Manhours [30000 h] | 70,000 |  |
| 1.4.3.3.1.3.140 |  | Install ceramic tiling work | 25d | 2012-10-22 | 2012-11-14 | 1.4.3.3.1.3.130 SS+7d | 122d | 0d | SSH-Construction Manhours [30000 h] | 25,000 |  |
| 1.4.3.3.1.3.150 |  | Install textured painted work on CMU wall | 23.75d | 2012-10-29 | 2012-11-20 | 1.4.3.3.1.3.140 SS+7d | 122.25d | 42.25d | SSH-Construction Manhours [28500 h] | 33,750 | 0.0099696395 |
|  | 4 | **Ceiling Finihsing** |  | 2012-09-16 | 2012-10-22 |  |  |  |  |  |  |
| 1.4.3.3.1.3.160 |  | Install gypsum board ceiling system | 25d | 2012-09-16 | 2012-10-09 | 1.4.3.3.1.3.100 | 122d | 0d | SSH-Construction Manhours [12000 h] | 5,400 |  |
| 1.4.3.3.1.3.170 |  | Install painting work | 25d | 2012-09-23 | 2012-10-15 | 1.4.3.3.1.3.160 SS+7d | 122d | 0d | SSH-Construction Manhours [10000 h] | 4,200 |  |
| 1.4.3.3.1.3.180 |  | Install roof water proofing system & scrupper | 25d | 2012-09-29 | 2012-10-22 | 1.4.3.3.1.3.170 SS+7d | 153d | 73d | SSH-Construction Manhours [10000 h] | 30,000 | 0.0088619018 |
|  | 5 | **Doors / Windows / Toilet Accs** |  | 2012-09-27 | 2012-10-31 |  |  |  |  |  |  |
| 1.4.3.3.1.3.190 |  | Install doors & windows | 25d | 2012-09-27 | 2012-10-21 | 1.4.3.3.1.3.290, 1.4.3.3.1.3.270 | 143.5d | 0d | SSH-Construction Manhours [10000 h] | 18,000 |  |
| 1.4.3.3.1.3.200 |  | Install toilet fixtures & accs | 25d | 2012-10-04 | 2012-10-28 | 1.4.3.3.1.3.190 SS+7.5d | 143.5d | 0d | SSH-Construction Manhours [16000 h] | 180,000 |  |
| 1.4.3.3.1.3.210 |  | Install cabinet & counter top | 25d | 2012-10-08 | 2012-10-31 | 1.4.3.3.1.3.200 SS+3d | 143.5d | 63.5d | SSH-Construction Manhours [16000 h] | 165,000 | 0.04874046 |
|  | 4 | **Electrical works** |  | 2012-08-14 | 2012-09-11 |  |  |  |  |  |  |
| 1.4.3.3.1.3.220 |  | Install electric conduits / fittings | 15d | 2012-08-14 | 2012-08-28 | 1.4.3.3.1.3.090 SS | 161.5d | 0d | SSH-Construction Manhours [3834.32 h] | 18,190 |  |
| 1.4.3.3.1.3.230 |  | Install cables / wires | 15d | 2012-08-16 | 2012-08-30 | 1.4.3.3.1.3.220 SS+3d | 161.5d | 0d | SSH-Construction Manhours [5751.49 h] | 125,000 |  |
| 1.4.3.3.1.3.240 |  | Install lighting fixtures | 15d | 2012-08-20 | 2012-09-03 | 1.4.3.3.1.3.230 SS+3d | 161.5d | 0d | SSH-Construction Manhours [5751.49 h] | 35,000 |  |
| 1.4.3.3.1.3.250 |  | Install panelboards | 15d | 2012-08-22 | 2012-09-05 | 1.4.3.3.1.3.240 SS+3d | 161.5d | 0d | SSH-Construction Manhours [2400 h] | 5,000 |  |
| 1.4.3.3.1.3.255 |  | Install lighting control panel | 15d | 2012-08-25 | 2012-09-08 | 1.4.3.3.1.3.250 SS+2d | 161.5d | 0d | SSH-Construction Manhours [2400 h] | 5,250 | 0.0015508328 |
| 1.4.3.3.1.3.260 |  | Install disconnect switches | 15d | 2012-08-26 | 2012-09-09 | 1.4.3.3.1.3.250 SS+2d, 1.4.3.3.1.3.255 SS+2d | 161.5d | 0d | SSH-Construction Manhours [2400 h] | 350 |  |
| 1.4.3.3.1.3.270 |  | Install grounding system | 15d | 2012-08-28 | 2012-09-11 | 1.4.3.3.1.3.260 SS+2d | 161.5d | 18d | SSH-Construction Manhours [2400 h] | 7,500 |  |

| ID | WBS | Activity | Duration | Start | Finish | Predecessors | Total float | Free float | Resources | Cost | QTY |
| --- | --- | --- | --- | --- | --- | --- | --- | --- | --- | --- | --- |
|  | 5 | **Water Supply System** |  | 2012-09-06 | 2012-09-20 |  |  |  |  |  |  |
| 1.4.3.3.1.3.280 |  | Install water supply system | 15d | 2012-09-06 | 2012-09-20 | 1.4.3.3.1.3.090 | 143.5d | 0d | SSH-Construction Manhours [3600 h] | 30,000 | 0.0088619018 |
|  | 6 | **Sewer System** |  | 2012-09-13 | 2012-09-27 |  |  |  |  |  |  |
| 1.4.3.3.1.3.290 |  | Install sewer system | 15d | 2012-09-13 | 2012-09-27 | 1.4.3.3.1.3.280 SS+8d | 143.5d | 0d | SSH-Construction Manhours [3600 h] | 35,000 | 0.0103388854 |
|  | 7 | **HVAC System** |  | 2012-09-27 | 2012-10-11 |  |  |  |  |  |  |
| 1.4.3.3.1.3.300 |  | Install HVAC system | 15d | 2012-09-27 | 2012-10-11 | 1.4.3.3.1.3.290 | 164d | 84d | SSH-Construction Manhours [9600 h] | 30,000 | 0.0088619018 |
|  | 4 | **Snack Booths (4 nos)** |  | 2012-03-17 | 2012-11-13 |  |  |  |  |  |  |
|  | 1 | **Snack Booth # 1** |  | 2012-03-17 | 2012-08-11 |  |  |  |  |  |  |
|  | 1 | **Civil work** |  | 2012-03-17 | 2012-06-07 |  |  |  |  |  |  |
| 1.4.3.4.1.010 |  | Excavation leveling & compaction for snack booth #1 | 10d | 2012-03-17 | 2012-03-25 | 1.4.3.3.1.1.010 SS | 37.75d | 0d | SSH-Construction Manhours [4000 h]; Excavator [80 h]; Dump Truck [80 h] | 475 |  |
| 1.4.3.4.1.015 |  | Backfill/comp for snack booth #1 | 12.5d | 2012-05-27 | 2012-06-07 | 1.4.3.4.1.050 | 182.25d | 7.25d | SSH-Construction Manhours [2000 h]; Compactor [100 h]; Dump Truck [100 h] | 313 | 9.24592E-005 |
|  | 2 | **Structural work** |  | 2012-03-21 | 2012-05-27 |  |  |  |  |  |  |
| 1.4.3.4.1.020 |  | Install lean concrete for reinforced fdns for snack both 1 | 18.75d | 2012-03-21 | 2012-04-08 | 1.4.3.4.1.010 SS+6d | 157d | 0d | SSH-Construction Manhours [10500 h] | 446 |  |
| 1.4.3.4.1.030 |  | Install reinforced fdns for snack booth1 | 31.25d | 2012-03-31 | 2012-04-29 | 1.4.3.4.1.020 SS+10d | 157d | 0d | SSH-Construction Manhours [50000 h] | 4,650 |  |
| 1.4.3.4.1.040 |  | Install reinforced roof slab/paraphet snack booth1 | 31.25d | 2012-04-14 | 2012-05-13 | 1.4.3.4.1.030 SS+15d | 157d | 0d | SSH-Construction Manhours [15000 h] | 4,650 |  |
| 1.4.3.4.1.050 |  | Install reinforced slab on grade | 31.25d | 2012-04-28 | 2012-05-27 | 1.4.3.4.1.040 SS+15d | 157d | 0d | SSH-Construction Manhours [15000 h] | 3,760 | 0.0011106917 |
|  | 3 | **Architectural work** |  | 2012-05-12 | 2012-08-11 |  |  |  |  |  |  |
| 1.4.3.4.1.060 |  | Install masonry work for snack booth1 | 18.75d | 2012-05-12 | 2012-05-29 | 1.4.3.4.1.050 SS+15d | 157d | 0d | SSH-Construction Manhours [6000 h] | 4,655 |  |
| 1.4.3.4.1.070 |  | Install plastering work | 18.75d | 2012-05-17 | 2012-06-04 | 1.4.3.4.1.060 SS+6d | 157d | 0d | SSH-Construction Manhours [3000 h] | 4,912 |  |
| 1.4.3.4.1.080 |  | Install roof proofing system | 18.75d | 2012-05-22 | 2012-06-09 | 1.4.3.4.1.070 SS+5d | 157d | 0d | SSH-Construction Manhours [3000 h] | 7,500 |  |
| 1.4.3.4.1.090 |  | Install ceiling system | 18.75d | 2012-05-27 | 2012-06-13 | 1.4.3.4.1.080 SS+5d | 175d | 0d | SSH-Construction Manhours [3000 h] | 525 |  |
| 1.4.3.4.1.100 |  | Install concret toping, ceramic floor finishes | 18.75d | 2012-05-31 | 2012-06-18 | 1.4.3.4.1.090 SS+5d | 175d | 0d | SSH-Construction Manhours [9000 h] | 1,575 |  |
| 1.4.3.4.1.110 |  | Install painting work | 18.75d | 2012-06-05 | 2012-06-23 | 1.4.3.4.1.100 SS+5d | 175d | 0d | SSH-Construction Manhours [9000 h] | 5,438 |  |
| 1.4.3.4.1.120 |  | Install plumbing fixture | 18.75d | 2012-06-10 | 2012-06-27 | 1.4.3.4.1.110 SS+5d | 175d | 0d | SSH-Construction Manhours [9000 h] | 4,501 |  |
| 1.4.3.4.1.130 |  | Install doors | 18.75d | 2012-06-14 | 2012-07-02 | 1.4.3.4.1.120 SS+5d, 1.4.3.4.1.015 | 175d | 0d | SSH-Construction Manhours [3000 h] | 4,650 |  |
| 1.4.3.4.1.140 |  | Install windows | 18.75d | 2012-06-20 | 2012-07-08 | 1.4.3.4.1.130 SS+6.25d | 175d | 0d | SSH-Construction Manhours [3000 h] | 3,515 |  |
| 1.4.3.4.1.150 |  | Install furniture & kitchen counter top | 18.75d | 2012-06-26 | 2012-07-14 | 1.4.3.4.1.140 SS+6.25d | 175d | 0d | SSH-Construction Manhours [3000 h] | 15,000 |  |
| 1.4.3.4.1.160 |  | Install kitchen & dinnning equipments | 18.75d | 2012-07-02 | 2012-07-19 | 1.4.3.4.1.150 SS+6.25d | 175d | 18d | SSH-Construction Manhours [3000 h] | 30,000 |  |
| 1.4.3.4.1.170 |  | Install wooden trellis | 18.75d | 2012-07-25 | 2012-08-11 | 1.4.3.4.1.160 SS+6.25d, 1.4.3.4.1.330 | 157d | 0d | SSH-Construction Manhours [3000 h] | 3,600 | 0.0010634282 |

| ID | WBS | Activity | Duration | Start | Finish | Predecessors | Total float | Free float | Resources | Cost | QTY |
| --- | --- | --- | --- | --- | --- | --- | --- | --- | --- | --- | --- |
|  | 4 | **Electrical work** |  | 2012-06-09 | 2012-07-12 |  |  |  |  |  |  |
| 1.4.3.4.1.180 |  | Install electric conduits | 18.75d | 2012-06-09 | 2012-06-26 | 1.4.3.4.1.080 | 157d | 0d | SSH-Construction Manhours [3000 h] | 1,875 |  |
| 1.4.3.4.1.190 |  | Install cables & wires | 18.75d | 2012-06-14 | 2012-07-02 | 1.4.3.4.1.180 SS+6d | 157d | 0d | SSH-Construction Manhours [3000 h] | 350 |  |
| 1.4.3.4.1.200 |  | Install lighting fixtures | 18.75d | 2012-06-18 | 2012-07-05 | 1.4.3.4.1.190 SS+4d | 157d | 0d | SSH-Construction Manhours [3000 h] | 4,500 |  |
| 1.4.3.4.1.210 |  | Install panelboards | 18.75d | 2012-06-21 | 2012-07-08 | 1.4.3.4.1.200 SS+3d | 157d | 0d | SSH-Construction Manhours [3000 h] | 4,000 |  |
| 1.4.3.4.1.220 |  | Install grounding system | 18.75d | 2012-06-23 | 2012-07-10 | 1.4.3.4.1.210 SS+2d | 157d | 0d | SSH-Construction Manhours [3000 h] | 1,000 |  |
| 1.4.3.4.1.230 |  | Testing & commissioing of electric system | 18.75d | 2012-06-26 | 2012-07-12 | 1.4.3.4.1.220 SS+3d | 157d | 0d | SSH-Construction Manhours [3000 h] | 1,000 | 0.0002953967 |
|  | 5 | **Communciation work** |  | 2012-06-09 | 2012-07-24 |  |  |  |  |  |  |
| 1.4.3.4.1.240 |  | Install comm condutis & fittings | 12.5d | 2012-06-09 | 2012-06-20 | 1.4.3.4.1.180 SS | 164.75d | 0d | SSH-Construction Manhours [2000 h] | 750 |  |
| 1.4.3.4.1.250 |  | Install UTP cable | 12.5d | 2012-06-12 | 2012-06-24 | 1.4.3.4.1.240 SS+4d | 167.75d | 0d | SSH-Construction Manhours [4000 h] | 420 |  |
| 1.4.3.4.1.260 |  | Install equipment cabinet | 12.5d | 2012-06-17 | 2012-06-27 | 1.4.3.4.1.250 SS+4d | 167.75d | 0d | SSH-Construction Manhours [3000 h] | 2,600 |  |
| 1.4.3.4.1.270 |  | Install data network switch | 12.5d | 2012-06-18 | 2012-06-30 | 1.4.3.4.1.260 SS+2d | 167.75d | 0d | SSH-Construction Manhours [3000 h] | 40,000 |  |
| 1.4.3.4.1.280 |  | Install copper splice closure | 12.5d | 2012-06-20 | 2012-07-02 | 1.4.3.4.1.270 SS+2d | 167.75d | 0d | SSH-Construction Manhours [3000 h] | 10,000 |  |
| 1.4.3.4.1.290 |  | Install patch panel | 12.5d | 2012-06-21 | 2012-07-03 | 1.4.3.4.1.280 SS+2d | 167.75d | 0d | SSH-Construction Manhours [3000 h] | 8,000 |  |
| 1.4.3.4.1.300 |  | Install fiber patch panel | 12.5d | 2012-06-25 | 2012-07-07 | 1.4.3.4.1.290 SS+3d | 167.75d | 0d | SSH-Construction Manhours [3000 h] | 7,000 |  |
| 1.4.3.4.1.310 |  | Install patch cord | 12.5d | 2012-06-27 | 2012-07-09 | 1.4.3.4.1.300 SS+3d | 167.75d | 0d | SSH-Construction Manhours [3000 h] | 5,040 |  |
| 1.4.3.4.1.320 |  | Install rack manager | 12.5d | 2012-07-01 | 2012-07-11 | 1.4.3.4.1.310 SS+3d | 167.75d | 10.75d | SSH-Construction Manhours [3000 h] | 2,300 |  |
| 1.4.3.4.1.330 |  | Testing & commissioning of comm system | 12.5d | 2012-07-14 | 2012-07-24 | 1.4.3.4.1.320 SS+3d, 1.4.3.4.1.230, 1.4.3.4.1.360 | 157d | 0d | SSH-Construction Manhours [5000 h] | 2,500 | 0.0007384918 |
|  | 6 | **Mechanical work** |  | 2012-06-09 | 2012-07-05 |  |  |  |  |  |  |
| 1.4.3.4.1.340 |  | Install water supply system | 15d | 2012-06-09 | 2012-06-23 | 1.4.3.4.1.240 SS | 164.75d | 0d | SSH-Construction Manhours [7200 h] | 2,500 |  |
| 1.4.3.4.1.350 |  | Install sewer system | 15d | 2012-06-16 | 2012-06-30 | 1.4.3.4.1.340 SS+7d | 164.75d | 0d | SSH-Construction Manhours [7200 h] | 3,500 |  |
| 1.4.3.4.1.360 |  | Install HVAC system | 15d | 2012-06-21 | 2012-07-05 | 1.4.3.4.1.350 SS+7d | 164.75d | 7.75d | SSH-Construction Manhours [6000 h] | 12,500 | 0.0036924591 |
|  | 2 | **Snack Booth # 2** |  | 2012-04-18 | 2012-09-20 |  |  |  |  |  |  |
|  | 1 | **Civil work** |  | 2012-04-18 | 2012-08-02 |  |  |  |  |  |  |
| 1.4.3.4.2.010 |  | Excavation leveling & compaction for snack booth #2 | 37.5d | 2012-04-18 | 2012-05-22 | 1.4.3.4.1.010 SS+35d | 128.75d | 0d | SSH-Construction Manhours [15000 h]; Dump Truck [300 h]; Excavator [300 h] | 475 |  |
| 1.4.3.4.2.015 |  | Backfill/comp for snack booth #2 | 37.5d | 2012-06-28 | 2012-08-02 | 1.4.3.4.2.050 | 174d | 17d | SSH-Construction Manhours [12000 h]; Dump Truck [300 h]; Compactor [300 h] | 313 | 9.24592E-005 |

| ID | WBS | Activity | Duration | Start | Finish | Predecessors | Total float | Free float | Resources | Cost | QTY |
| --- | --- | --- | --- | --- | --- | --- | --- | --- | --- | --- | --- |
|  | 2 | **Structural work** |  | 2012-04-23 | 2012-06-28 |  |  |  |  |  |  |
| 1.4.3.4.2.020 |  | Install lean concrete for reinforced fdns for snack both | 18.75d | 2012-04-23 | 2012-05-10 | 1.4.3.4.2.010 SS+6d | 174d | 0d | SSH-Construction Manhours [7500 h] | 446 |  |
| 1.4.3.4.2.030 |  | Install reinforced fdns for snack booth | 31.25d | 2012-05-02 | 2012-05-31 | 1.4.3.4.2.020 SS+10d | 174d | 0d | SSH-Construction Manhours [10000 h] | 4,650 |  |
| 1.4.3.4.2.040 |  | Install reinforced roof slab/paraphet snack booth | 31.25d | 2012-05-16 | 2012-06-14 | 1.4.3.4.2.030 SS+15d | 174d | 0d | SSH-Construction Manhours [10000 h] | 4,650 |  |
| 1.4.3.4.2.050 |  | Install reinforced slab on grade | 31.25d | 2012-05-30 | 2012-06-28 | 1.4.3.4.2.040 SS+15d | 174d | 0d | SSH-Construction Manhours [10000 h] | 3,760 | 0.0011106917 |
|  | 3 | **Architectural work** |  | 2012-06-13 | 2012-09-20 |  |  |  |  |  |  |
| 1.4.3.4.2.060 |  | Install masonry work for snack booth | 18.75d | 2012-06-13 | 2012-07-01 | 1.4.3.4.2.050 SS+15d | 174d | 0d | SSH-Construction Manhours [9000 h] | 4,655 |  |
| 1.4.3.4.2.070 |  | Install plastering work | 18.75d | 2012-06-19 | 2012-07-07 | 1.4.3.4.2.060 SS+6d | 174d | 0d | SSH-Construction Manhours [9000 h] | 4,912 |  |
| 1.4.3.4.2.080 |  | Install roof proofing system | 18.75d | 2012-06-24 | 2012-07-11 | 1.4.3.4.2.070 SS+5d | 174d | 0d | SSH-Construction Manhours [9000 h] | 7,500 |  |
| 1.4.3.4.2.090 |  | Install ceiling system | 18.75d | 2012-06-28 | 2012-07-16 | 1.4.3.4.2.080 SS+5d | 194.75d | 0d | SSH-Construction Manhours [9000 h] | 525 |  |
| 1.4.3.4.2.100 |  | Install concrete toping, ceramic floor finishes | 18.75d | 2012-07-03 | 2012-07-21 | 1.4.3.4.2.090 SS+5d | 194.75d | 37.75d | SSH-Construction Manhours [9000 h] | 1,575 |  |
| 1.4.3.4.2.110 |  | Install painting work | 18.75d | 2012-08-12 | 2012-08-28 | 1.4.3.4.2.100 SS+4d, 1.4.3.4.1.170 | 157d | 0d | SSH-Construction Manhours [7500 h] | 5,438 |  |
| 1.4.3.4.2.120 |  | Install plumbing fixture | 18.75d | 2012-08-15 | 2012-09-02 | 1.4.3.4.2.110 SS+4d | 157d | 0d | SSH-Construction Manhours [7500 h] | 4,501 |  |
| 1.4.3.4.2.130 |  | Install doors | 18.75d | 2012-08-19 | 2012-09-05 | 1.4.3.4.2.120 SS+4d, 1.4.3.4.2.015 | 157d | 0d | SSH-Construction Manhours [7500 h] | 4,650 |  |
| 1.4.3.4.2.140 |  | Install windows | 18.75d | 2012-08-21 | 2012-09-06 | 1.4.3.4.2.130 SS+2d | 157d | 0d | SSH-Construction Manhours [4500 h] | 3,515 |  |
| 1.4.3.4.2.150 |  | Install furniture & kitchen counter top | 18.75d | 2012-08-22 | 2012-09-09 | 1.4.3.4.2.140 SS+2d | 157d | 0d | SSH-Construction Manhours [4500 h] | 15,000 |  |
| 1.4.3.4.2.160 |  | Install kitchen & dinnning equipments | 18.75d | 2012-08-28 | 2012-09-15 | 1.4.3.4.2.150 SS+6d | 157d | 0d | SSH-Construction Manhours [4500 h] | 30,000 |  |
| 1.4.3.4.2.170 |  | Install wooden trellis | 18.75d | 2012-09-03 | 2012-09-20 | 1.4.3.4.2.160 SS+6d, 1.4.3.4.2.230 | 157d | 0d | SSH-Construction Manhours [4500 h] | 3,600 | 0.0010634282 |
|  | 4 | **Electrical work** |  | 2012-07-11 | 2012-08-11 |  |  |  |  |  |  |
| 1.4.3.4.2.180 |  | Install electric conduits | 15d | 2012-07-11 | 2012-07-25 | 1.4.3.4.2.080 | 174d | 0d | SSH-Construction Manhours [6000 h] | 1,875 |  |
| 1.4.3.4.2.190 |  | Install cables & wires | 15d | 2012-07-17 | 2012-07-31 | 1.4.3.4.2.180 SS+6d | 174d | 0d | SSH-Construction Manhours [6000 h] | 350 |  |
| 1.4.3.4.2.200 |  | Install lighting fixtures | 15d | 2012-07-21 | 2012-08-04 | 1.4.3.4.2.190 SS+4d | 174d | 0d | SSH-Construction Manhours [6000 h] | 4,500 |  |
| 1.4.3.4.2.210 |  | Install panelboards | 15d | 2012-07-24 | 2012-08-06 | 1.4.3.4.2.200 SS+3d | 174d | 0d | SSH-Construction Manhours [6000 h] | 4,000 |  |
| 1.4.3.4.2.220 |  | Install grounding system | 15d | 2012-07-25 | 2012-08-08 | 1.4.3.4.2.210 SS+2d | 174d | 0d | SSH-Construction Manhours [6000 h] | 1,000 |  |
| 1.4.3.4.2.230 |  | Testing & commissioing of electric system | 15d | 2012-07-29 | 2012-08-11 | 1.4.3.4.2.220 SS+3d | 174d | 0d | SSH-Construction Manhours [6000 h] | 1,000 | 0.0002953967 |

| ID | WBS | Activity | Duration | Start | Finish | Predecessors | Total float | Free float | Resources | Cost | QTY |
| --- | --- | --- | --- | --- | --- | --- | --- | --- | --- | --- | --- |
|  | 5 | **Communciation work** |  | 2012-07-11 | 2012-08-25 |  |  |  |  |  |  |
| 1.4.3.4.2.240 |  | Install comm condutis & fittings | 15d | 2012-07-11 | 2012-07-25 | 1.4.3.4.2.180 SS | 178d | 0d | SSH-Construction Manhours [6000 h] | 750 |  |
| 1.4.3.4.2.250 |  | Install UTP cable | 15d | 2012-07-15 | 2012-07-29 | 1.4.3.4.2.240 SS+4d | 181d | 0d | SSH-Construction Manhours [6000 h] | 420 |  |
| 1.4.3.4.2.260 |  | Install equipment cabinet | 15d | 2012-07-19 | 2012-08-01 | 1.4.3.4.2.250 SS+4d | 181d | 0d | SSH-Construction Manhours [6000 h] | 2,600 |  |
| 1.4.3.4.2.270 |  | Install data network switch | 15d | 2012-07-21 | 2012-08-04 | 1.4.3.4.2.260 SS+2d | 181d | 0d | SSH-Construction Manhours [6000 h] | 40,000 |  |
| 1.4.3.4.2.280 |  | Install copper splice closure | 15d | 2012-07-23 | 2012-08-06 | 1.4.3.4.2.270 SS+2d | 181d | 0d | SSH-Construction Manhours [6000 h] | 10,000 |  |
| 1.4.3.4.2.290 |  | Install patch panel | 15d | 2012-07-24 | 2012-08-07 | 1.4.3.4.2.280 SS+2d | 181d | 0d | SSH-Construction Manhours [6000 h] | 8,000 |  |
| 1.4.3.4.2.300 |  | Install fiber patch panel | 15d | 2012-07-28 | 2012-08-11 | 1.4.3.4.2.290 SS+3d | 181d | 0d | SSH-Construction Manhours [6000 h] | 7,000 |  |
| 1.4.3.4.2.310 |  | Install patch cord | 15d | 2012-07-30 | 2012-08-13 | 1.4.3.4.2.300 SS+3d | 181d | 0d | SSH-Construction Manhours [6000 h] | 5,040 |  |
| 1.4.3.4.2.320 |  | Install rack manager | 15d | 2012-08-02 | 2012-08-15 | 1.4.3.4.2.310 SS+3d | 181d | 7d | SSH-Construction Manhours [6000 h] | 2,300 |  |
| 1.4.3.4.2.330 |  | Testing & commissioning of comm system | 15d | 2012-08-12 | 2012-08-25 | 1.4.3.4.2.320 SS+3d, 1.4.3.4.2.230, 1.4.3.4.2.360 | 174d | 17d | SSH-Construction Manhours [6000 h] | 2,500 | 0.0007384918 |
|  | 6 | **Mechanical work** |  | 2012-07-11 | 2012-08-07 |  |  |  |  |  |  |
| 1.4.3.4.2.340 |  | Install water supply system | 15d | 2012-07-11 | 2012-07-25 | 1.4.3.4.2.240 SS | 178d | 0d | SSH-Construction Manhours [6000 h] | 2,500 |  |
| 1.4.3.4.2.350 |  | Install sewer system | 15d | 2012-07-18 | 2012-08-01 | 1.4.3.4.2.340 SS+7d | 178d | 0d | SSH-Construction Manhours [6000 h] | 3,500 |  |
| 1.4.3.4.2.360 |  | Install HVAC system | 15d | 2012-07-24 | 2012-08-07 | 1.4.3.4.2.350 SS+7d | 178d | 4d | SSH-Construction Manhours [6000 h] | 12,500 | 0.0036924591 |
|  | 3 | **Snack Booth # 3** |  | 2012-05-21 | 2012-11-13 |  |  |  |  |  |  |
|  | 1 | **Civil work** |  | 2012-05-21 | 2012-08-12 |  |  |  |  |  |  |
| 1.4.3.4.3.010 |  | Excavation leveling & compaction for snack booth 3 | 10d | 2012-05-21 | 2012-05-29 | 1.4.3.4.2.010 SS+35d | 128.75d | 0d | SSH-Construction Manhours [2400 h]; Excavator [80 h]; Dump Truck [80 h] | 475 |  |
| 1.4.3.4.3.015 |  | Backfill/comp for snack booth 3 | 12.5d | 2012-07-31 | 2012-08-12 | 1.4.3.4.3.050 | 188d | 31d | SSH-Construction Manhours [3000 h]; Dump Truck [100 h]; Compactor [100 h] | 313 | 9.24592E-005 |
|  | 2 | **Structural work** |  | 2012-05-26 | 2012-07-31 |  |  |  |  |  |  |
| 1.4.3.4.3.020 |  | Install lean concrete for reinforced fdns for snack both | 18.75d | 2012-05-26 | 2012-06-12 | 1.4.3.4.3.010 SS+6d | 128.75d | 0d | SSH-Construction Manhours [4500 h] | 446 |  |
| 1.4.3.4.3.030 |  | Install reinforced fdns for snack booth | 31.25d | 2012-06-04 | 2012-07-03 | 1.4.3.4.3.020 SS+10d | 128.75d | 0d | SSH-Construction Manhours [25000 h] | 4,650 |  |
| 1.4.3.4.3.040 |  | Install reinforced roof slab/paraphet snack booth | 31.25d | 2012-06-18 | 2012-07-17 | 1.4.3.4.3.030 SS+15d | 128.75d | 0d | SSH-Construction Manhours [25000 h] | 4,650 |  |
| 1.4.3.4.3.050 |  | Install reinforced slab on grade | 31.25d | 2012-07-02 | 2012-07-31 | 1.4.3.4.3.040 SS+15d | 128.75d | 0d | SSH-Construction Manhours [12500 h] | 3,760 | 0.0011106917 |

| ID | WBS | Activity | Duration | Start | Finish | Predecessors | Total float | Free float | Resources | Cost | QTY |
| --- | --- | --- | --- | --- | --- | --- | --- | --- | --- | --- | --- |
|  | 3 | **Architectural work** |  | 2012-07-16 | 2012-11-13 |  |  |  |  |  |  |
| 1.4.3.4.3.060 |  | Install masonry work for snack booth | 25d | 2012-07-16 | 2012-08-08 | 1.4.3.4.3.050 SS+15d | 128.75d | 0d | SSH-Construction Manhours [10000 h] | 4,655 |  |
| 1.4.3.4.3.070 |  | Install plastering work | 25d | 2012-07-22 | 2012-08-14 | 1.4.3.4.3.060 SS+6d | 128.75d | 0d | SSH-Construction Manhours [10000 h] | 4,912 |  |
| 1.4.3.4.3.080 |  | Install roof proofing system | 25d | 2012-07-26 | 2012-08-19 | 1.4.3.4.3.070 SS+5d | 128.75d | 0d | SSH-Construction Manhours [10000 h] | 7,500 |  |
| 1.4.3.4.3.090 |  | Install ceiling system | 25d | 2012-07-31 | 2012-08-23 | 1.4.3.4.3.080 SS+5d | 183.75d | 0d | SSH-Construction Manhours [10000 h] | 525 |  |
| 1.4.3.4.3.100 |  | Install concrete toping, ceramic floor finishes | 25d | 2012-08-05 | 2012-08-28 | 1.4.3.4.3.090 SS+5d | 183.75d | 26.75d | SSH-Construction Manhours [10000 h] | 1,575 |  |
| 1.4.3.4.3.110 |  | Install painting work | 25d | 2012-09-03 | 2012-09-26 | 1.4.3.4.3.100 SS+4d, 1.4.3.4.2.170 SS | 157d | 0d | SSH-Construction Manhours [10000 h] | 5,438 |  |
| 1.4.3.4.3.120 |  | Install plumbing fixture | 25d | 2012-09-06 | 2012-09-30 | 1.4.3.4.3.110 SS+4d | 157d | 0d | SSH-Construction Manhours [8000 h] | 4,501 |  |
| 1.4.3.4.3.130 |  | Install doors | 25d | 2012-09-10 | 2012-10-03 | 1.4.3.4.3.120 SS+4d, 1.4.3.4.2.330, 1.4.3.4.3.015 | 157d | 0d | SSH-Construction Manhours [6000 h] | 4,650 |  |
| 1.4.3.4.3.140 |  | Install windows | 25d | 2012-09-12 | 2012-10-06 | 1.4.3.4.3.130 SS+2d | 157d | 0d | SSH-Construction Manhours [6000 h] | 3,515 |  |
| 1.4.3.4.3.150 |  | Install furniture & kitchen counter top | 25d | 2012-09-13 | 2012-10-07 | 1.4.3.4.3.140 SS+2d | 157d | 0d | SSH-Construction Manhours [6000 h] | 15,000 |  |
| 1.4.3.4.3.160 |  | Install kitchen & dinnning equipments | 25d | 2012-09-19 | 2012-10-13 | 1.4.3.4.3.150 SS+6d | 157d | 28.25d | SSH-Construction Manhours [6000 h] | 30,000 |  |
| 1.4.3.4.3.170 |  | Install wooden trellis | 25d | 2012-10-22 | 2012-11-13 | 1.4.3.4.3.160 SS+6d, 1.4.3.4.3.330 | 128.75d | 48.75d | SSH-Construction Manhours [20000 h] | 3,600 | 0.0010634282 |
|  | 4 | **Electrical work** |  | 2012-08-19 | 2012-09-27 |  |  |  |  |  |  |
| 1.4.3.4.3.180 |  | Install electric conduits | 25d | 2012-08-19 | 2012-09-11 | 1.4.3.4.3.080 | 128.75d | 0d | SSH-Construction Manhours [10000 h] | 1,875 |  |
| 1.4.3.4.3.190 |  | Install cables & wires | 25d | 2012-08-25 | 2012-09-17 | 1.4.3.4.3.180 SS+6d | 128.75d | 0d | SSH-Construction Manhours [10000 h] | 350 |  |
| 1.4.3.4.3.200 |  | Install lighting fixtures | 25d | 2012-08-28 | 2012-09-20 | 1.4.3.4.3.190 SS+4d | 128.75d | 0d | SSH-Construction Manhours [10000 h] | 4,500 |  |
| 1.4.3.4.3.210 |  | Install panelboards | 25d | 2012-09-01 | 2012-09-23 | 1.4.3.4.3.200 SS+3d | 128.75d | 0d | SSH-Construction Manhours [10000 h] | 4,000 |  |
| 1.4.3.4.3.220 |  | Install grounding system | 25d | 2012-09-02 | 2012-09-25 | 1.4.3.4.3.210 SS+2d | 128.75d | 0d | SSH-Construction Manhours [10000 h] | 1,000 |  |
| 1.4.3.4.3.230 |  | Testing & commissioing of electric system | 25d | 2012-09-05 | 2012-09-27 | 1.4.3.4.3.220 SS+3d | 128.75d | 0d | SSH-Construction Manhours [10000 h] | 1,000 | 0.0002953967 |
|  | 5 | **Communciation work** |  | 2012-08-19 | 2012-10-21 |  |  |  |  |  |  |
| 1.4.3.4.3.240 |  | Install comm condutis & fittings | 25d | 2012-08-19 | 2012-09-11 | 1.4.3.4.3.180 SS | 145.25d | 0d | SSH-Construction Manhours [10000 h] | 750 |  |
| 1.4.3.4.3.250 |  | Install UTP cable | 25d | 2012-08-22 | 2012-09-15 | 1.4.3.4.3.240 SS+4d | 145.75d | 0d | SSH-Construction Manhours [10000 h] | 420 |  |
| 1.4.3.4.3.260 |  | Install equipment cabinet | 25d | 2012-08-27 | 2012-09-18 | 1.4.3.4.3.250 SS+4d | 145.75d | 0d | SSH-Construction Manhours [10000 h] | 2,600 |  |
| 1.4.3.4.3.270 |  | Install data network switch | 25d | 2012-08-28 | 2012-09-20 | 1.4.3.4.3.260 SS+2d | 145.75d | 0d | SSH-Construction Manhours [10000 h] | 40,000 |  |
| 1.4.3.4.3.280 |  | Install copper splice closure | 25d | 2012-08-30 | 2012-09-23 | 1.4.3.4.3.270 SS+2d | 145.75d | 0d | SSH-Construction Manhours [10000 h] | 10,000 |  |
| 1.4.3.4.3.290 |  | Install patch panel | 25d | 2012-09-01 | 2012-09-24 | 1.4.3.4.3.280 SS+2d | 145.75d | 0d | SSH-Construction Manhours [6000 h] | 8,000 |  |
| 1.4.3.4.3.300 |  | Install fiber patch panel | 25d | 2012-09-04 | 2012-09-27 | 1.4.3.4.3.290 SS+3d | 145.75d | 0d | SSH-Construction Manhours [6000 h] | 7,000 |  |
| 1.4.3.4.3.310 |  | Install patch cord | 25d | 2012-09-06 | 2012-09-30 | 1.4.3.4.3.300 SS+3d | 145.75d | 0d | SSH-Construction Manhours [10000 h] | 5,040 |  |
| 1.4.3.4.3.320 |  | Install rack manager | 25d | 2012-09-10 | 2012-10-02 | 1.4.3.4.3.310 SS+3d | 145.75d | 17d | SSH-Construction Manhours [10000 h] | 2,300 |  |
| 1.4.3.4.3.330 |  | Testing & commissioning of comm system | 25d | 2012-09-29 | 2012-10-21 | 1.4.3.4.3.320 SS+3d, 1.4.3.4.3.230, 1.4.3.4.3.360 | 128.75d | 0d | SSH-Construction Manhours [10000 h] | 2,500 | 0.0007384918 |

| ID | WBS | Activity | Duration | Start | Finish | Predecessors | Total float | Free float | Resources | Cost | QTY |
| --- | --- | --- | --- | --- | --- | --- | --- | --- | --- | --- | --- |
|  | 6 | **Mechanical work** |  | 2012-08-19 | 2012-09-12 |  |  |  |  |  |  |
| 1.4.3.4.3.340 |  | Install water supply system | 12.5d | 2012-08-19 | 2012-08-30 | 1.4.3.4.3.240 SS | 145.25d | 0d | SSH-Construction Manhours [5000 h] | 2,500 |  |
| 1.4.3.4.3.350 |  | Install sewer system | 12.5d | 2012-08-26 | 2012-09-06 | 1.4.3.4.3.340 SS+7d | 145.25d | 0d | SSH-Construction Manhours [5000 h] | 3,500 |  |
| 1.4.3.4.3.360 |  | Install HVAC system | 12.5d | 2012-09-01 | 2012-09-12 | 1.4.3.4.3.350 SS+7d | 145.25d | 16.5d | SSH-Construction Manhours [5000 h] | 12,500 | 0.0036924591 |
|  | 4 | **Snack Booth # 4** |  | 2012-06-23 | 2012-11-04 |  |  |  |  |  |  |
|  | 1 | **Civil work** |  | 2012-06-23 | 2012-09-13 |  |  |  |  |  |  |
| 1.4.3.4.4.010 |  | Excavation leveling & compaction for snack booth 4 | 10d | 2012-06-23 | 2012-07-01 | 1.4.3.4.3.010 SS+35d | 139.5d | 0d | SSH-Construction Manhours [2400 h]; Excavator [80 h]; Dump Truck [80 h] | 475 |  |
| 1.4.3.4.4.015 |  | Backfill/comp for snack booth 4 | 12.5d | 2012-09-02 | 2012-09-13 | 1.4.3.4.4.050 | 165.5d | 11.75d | SSH-Construction Manhours [3000 h]; Dump Truck [100 h]; Compactor [100 h] | 313 | 9.24592E-005 |
|  | 2 | **Structural work** |  | 2012-06-27 | 2012-09-02 |  |  |  |  |  |  |
| 1.4.3.4.4.020 |  | Install lean concrete for reinforced fdns for snack both | 18.75d | 2012-06-27 | 2012-07-15 | 1.4.3.4.4.010 SS+6d | 139.5d | 0d | SSH-Construction Manhours [7500 h] | 446 |  |
| 1.4.3.4.4.030 |  | Install reinforced fdns for snack booth | 31.25d | 2012-07-07 | 2012-08-05 | 1.4.3.4.4.020 SS+10d | 139.5d | 0d | SSH-Construction Manhours [25000 h] | 4,650 |  |
| 1.4.3.4.4.040 |  | Install reinforced roof slab/paraphet snack booth | 31.25d | 2012-07-21 | 2012-08-19 | 1.4.3.4.4.030 SS+15d | 139.5d | 0d | SSH-Construction Manhours [12500 h] | 4,650 |  |
| 1.4.3.4.4.050 |  | Install reinforced slab on grade | 31.25d | 2012-08-04 | 2012-09-02 | 1.4.3.4.4.040 SS+15d | 139.5d | 0d | SSH-Construction Manhours [12500 h] | 3,760 | 0.0011106917 |
|  | 3 | **Architectural work** |  | 2012-08-18 | 2012-11-04 |  |  |  |  |  |  |
| 1.4.3.4.4.060 |  | Install masonry work for snack booth | 12.5d | 2012-08-18 | 2012-08-29 | 1.4.3.4.4.050 SS+15d | 139.5d | 0d | SSH-Construction Manhours [5000 h] | 4,655 |  |
| 1.4.3.4.4.070 |  | Install plastering work | 12.5d | 2012-08-22 | 2012-09-03 | 1.4.3.4.4.060 SS+5d | 139.5d | 0d | SSH-Construction Manhours [5000 h] | 4,912 |  |
| 1.4.3.4.4.080 |  | Install roof proofing system | 12.5d | 2012-08-27 | 2012-09-08 | 1.4.3.4.4.070 SS+5d | 139.5d | 0d | SSH-Construction Manhours [5000 h] | 7,500 |  |
| 1.4.3.4.4.090 |  | Install ceiling system | 12.5d | 2012-09-01 | 2012-09-12 | 1.4.3.4.4.080 SS+5d | 153.75d | 0d | SSH-Construction Manhours [5000 h] | 525 |  |
| 1.4.3.4.4.100 |  | Install concrete toping, ceramic floor finishes | 12.5d | 2012-09-05 | 2012-09-17 | 1.4.3.4.4.090 SS+5d | 153.75d | 0d | SSH-Construction Manhours [5000 h] | 1,575 |  |
| 1.4.3.4.4.110 |  | Install painting work | 12.5d | 2012-09-17 | 2012-09-29 | 1.4.3.4.4.100 SS+12.5d | 153.75d | 0d | SSH-Construction Manhours [5000 h] | 5,438 |  |
| 1.4.3.4.4.120 |  | Install plumbing fixture | 12.5d | 2012-09-22 | 2012-10-02 | 1.4.3.4.4.110 SS+4d | 153.75d | 0d | SSH-Construction Manhours [4000 h] | 4,501 |  |
| 1.4.3.4.4.130 |  | Install doors | 12.5d | 2012-09-25 | 2012-10-07 | 1.4.3.4.4.120 SS+4d, 1.4.3.4.4.015 | 153.75d | 0d | SSH-Construction Manhours [4000 h] | 4,650 |  |
| 1.4.3.4.4.140 |  | Install windows | 12.5d | 2012-09-26 | 2012-10-08 | 1.4.3.4.4.130 SS+2d | 153.75d | 0d | SSH-Construction Manhours [4000 h] | 3,515 |  |
| 1.4.3.4.4.150 |  | Install furniture & kitchen counter top | 12.5d | 2012-09-29 | 2012-10-10 | 1.4.3.4.4.140 SS+2d | 153.75d | 0d | SSH-Construction Manhours [4000 h] | 15,000 |  |
| 1.4.3.4.4.160 |  | Install kitchen & dinnning equipments | 12.5d | 2012-10-04 | 2012-10-16 | 1.4.3.4.4.150 SS+6d | 153.75d | 14.25d | SSH-Construction Manhours [4000 h] | 30,000 |  |
| 1.4.3.4.4.170 |  | Install wooden trellis | 12.5d | 2012-10-23 | 2012-11-04 | 1.4.3.4.4.160 SS+6d, 1.4.3.4.4.330 | 139.5d | 59.5d | SSH-Construction Manhours [7000 h] | 3,600 | 0.0010634282 |

| ID | WBS | Activity | Duration | Start | Finish | Predecessors | Total float | Free float | Resources | Cost | QTY |
| --- | --- | --- | --- | --- | --- | --- | --- | --- | --- | --- | --- |
|  | 4 | **Electrical work** |  | 2012-09-08 | 2012-10-07 |  |  |  |  |  |  |
| 1.4.3.4.4.180 |  | Install electric conduits | 12.5d | 2012-09-08 | 2012-09-19 | 1.4.3.4.4.080 | 139.5d | 0d | SSH-Construction Manhours [4000 h] | 1,875 |  |
| 1.4.3.4.4.190 |  | Install cables & wires | 12.5d | 2012-09-13 | 2012-09-25 | 1.4.3.4.4.180 SS+6d | 149d | 0d | SSH-Construction Manhours [3000 h] | 350 |  |
| 1.4.3.4.4.200 |  | Install lighting fixtures | 12.5d | 2012-09-17 | 2012-09-29 | 1.4.3.4.4.190 SS+4d | 149d | 0d | SSH-Construction Manhours [3000 h] | 4,500 |  |
| 1.4.3.4.4.210 |  | Install panelboards | 12.5d | 2012-09-20 | 2012-10-02 | 1.4.3.4.4.200 SS+3.75d | 149d | 0d | SSH-Construction Manhours [5000 h] | 4,000 |  |
| 1.4.3.4.4.220 |  | Install grounding system | 12.5d | 2012-09-23 | 2012-10-04 | 1.4.3.4.4.210 SS+2d | 149d | 0d | SSH-Construction Manhours [3000 h] | 1,000 |  |
| 1.4.3.4.4.230 |  | Testing & commissioing of electric system | 12.5d | 2012-09-25 | 2012-10-07 | 1.4.3.4.4.220 SS+3d | 149d | 9.5d | SSH-Construction Manhours [4000 h] | 1,000 | 0.0002953967 |
|  | 5 | **Communciation work** |  | 2012-09-19 | 2012-10-23 |  |  |  |  |  |  |
| 1.4.3.4.4.240 |  | Install comm condutis & fittings | 7.5d | 2012-09-19 | 2012-09-26 | 1.4.3.4.4.180 | 139.5d | 0d | SSH-Construction Manhours [1800 h] | 750 |  |
| 1.4.3.4.4.250 |  | Install UTP cable | 7.5d | 2012-09-24 | 2012-09-30 | 1.4.3.4.4.240 SS+4d | 139.5d | 0d | SSH-Construction Manhours [3000 h] | 420 |  |
| 1.4.3.4.4.260 |  | Install equipment cabinet | 7.5d | 2012-09-27 | 2012-10-04 | 1.4.3.4.4.250 SS+4d | 139.5d | 0d | SSH-Construction Manhours [1800 h] | 2,600 |  |
| 1.4.3.4.4.270 |  | Install data network switch | 7.5d | 2012-10-01 | 2012-10-08 | 1.4.3.4.4.260 SS+3.75d | 139.5d | 0d | SSH-Construction Manhours [1800 h] | 40,000 |  |
| 1.4.3.4.4.280 |  | Install copper splice closure | 7.5d | 2012-10-03 | 2012-10-10 | 1.4.3.4.4.270 SS+2.5d | 139.5d | 0d | SSH-Construction Manhours [2400 h] | 10,000 |  |
| 1.4.3.4.4.290 |  | Install patch panel | 7.5d | 2012-10-04 | 2012-10-11 | 1.4.3.4.4.280 SS+2d | 139.5d | 0d | SSH-Construction Manhours [2400 h] | 8,000 |  |
| 1.4.3.4.4.300 |  | Install fiber patch panel | 7.5d | 2012-10-08 | 2012-10-15 | 1.4.3.4.4.290 SS+3d | 139.5d | 0d | SSH-Construction Manhours [2400 h] | 7,000 |  |
| 1.4.3.4.4.310 |  | Install patch cord | 7.5d | 2012-10-10 | 2012-10-17 | 1.4.3.4.4.300 SS+3d | 139.5d | 0d | SSH-Construction Manhours [2400 h] | 5,040 |  |
| 1.4.3.4.4.320 |  | Install rack manager | 7.5d | 2012-10-14 | 2012-10-20 | 1.4.3.4.4.310 SS+3d | 139.5d | 0d | SSH-Construction Manhours [2400 h] | 2,300 |  |
| 1.4.3.4.4.330 |  | Testing & commissioning of comm system | 7.5d | 2012-10-16 | 2012-10-23 | 1.4.3.4.4.320 SS+3d, 1.4.3.4.4.230, 1.4.3.4.4.360 | 139.5d | 0d | SSH-Construction Manhours [2400 h] | 2,500 | 0.0007384918 |
|  | 6 | **Mechanical work** |  | 2012-09-26 | 2012-10-15 |  |  |  |  |  |  |
| 1.4.3.4.4.340 |  | Install water supply system | 8d | 2012-09-26 | 2012-10-04 | 1.4.3.4.4.240 | 140.25d | 0d | SSH-Construction Manhours [3200 h] | 2,500 |  |
| 1.4.3.4.4.350 |  | Install sewer system | 8d | 2012-10-03 | 2012-10-10 | 1.4.3.4.4.340 SS+7d | 140.25d | 0d | SSH-Construction Manhours [3200 h] | 3,500 |  |
| 1.4.3.4.4.360 |  | Install HVAC system | 6d | 2012-10-10 | 2012-10-15 | 1.4.3.4.4.350 SS+7d | 140.25d | 0.75d | SSH-Construction Manhours [2400 h] | 12,500 | 0.0036924591 |
|  | 5 | **Picnic Shelters (30 nos)** |  | 2012-03-17 | 2012-11-06 |  |  |  |  |  |  |
|  | 1 | **Picnic Shelters** |  | 2012-03-17 | 2012-11-06 |  |  |  |  |  |  |
|  | 1 | **Civil work** |  | 2012-03-17 | 2012-07-30 |  |  |  |  |  |  |
| 1.4.3.5.1.010 |  | Excavation for picnic shelters | 60d | 2012-03-17 | 2012-05-10 | 1.4.3.4.1.010 SS | 37.75d | 0d | SSH-Construction Manhours [24000 h]; Excavator [480 h]; Dump Truck [480 h] | 23,856 |  |
| 1.4.3.5.1.015 |  | Backfill/comp for picnic shelters | 60d | 2012-06-04 | 2012-07-30 | 1.4.3.5.1.040 SS+45d | 137.75d | 93.75d | SSH-Construction Manhours [14400 h]; Dump Truck [480 h]; Compactor [480 h] | 15,750 | 0.0046524985 |

| ID | WBS | Activity | Duration | Start | Finish | Predecessors | Total float | Free float | Resources | Cost | QTY |
| --- | --- | --- | --- | --- | --- | --- | --- | --- | --- | --- | --- |
|  | 2 | **Structural work** |  | 2012-03-21 | 2012-07-14 |  |  |  |  |  |  |
| 1.4.3.5.1.020 |  | Install lean concrete for reinforced fdns | 75d | 2012-03-21 | 2012-05-30 | 1.4.3.5.1.010 SS+6d | 44d | 0d | SSH-Construction Manhours [42000 h] | 18,900 |  |
| 1.4.3.5.1.030 |  | Install reinforced fdns | 87.5d | 2012-04-04 | 2012-06-25 | 1.4.3.5.1.020 SS+15d | 44d | 0d | SSH-Construction Manhours [140000 h] | 931,500 |  |
| 1.4.3.5.1.040 |  | Install reinforced roof slab on grade | 87.5d | 2012-04-23 | 2012-07-14 | 1.4.3.5.1.030 SS+20d | 44d | 0d | SSH-Construction Manhours [105000 h] | 129,605 | 0.0382848928 |
|  | 3 | **Architectural work** |  | 2012-05-12 | 2012-09-19 |  |  |  |  |  |  |
| 1.4.3.5.1.050 |  | Install cement based plaster/textured paintn finish | 90d | 2012-05-12 | 2012-08-04 | 1.4.3.5.1.040 SS+20d | 44d | 0d | SSH-Construction Manhours [57600 h] | 78,000 |  |
| 1.4.3.5.1.060 |  | Install roofing trellis system | 90d | 2012-05-23 | 2012-08-15 | 1.4.3.5.1.050 SS+12.5d | 44d | 0d | SSH-Construction Manhours [36000 h] | 193,200 |  |
| 1.4.3.5.1.070 |  | Install concrete topping, ceramic floor finish | 90d | 2012-06-04 | 2012-08-27 | 1.4.3.5.1.060 SS+12.5d | 44d | 0d | SSH-Construction Manhours [72000 h] | 93,600 |  |
| 1.4.3.5.1.080 |  | Install picnic furniture | 90d | 2012-06-16 | 2012-09-08 | 1.4.3.5.1.070 SS+12.5d | 172.75d | 0d | SSH-Construction Manhours [36000 h] | 150,000 |  |
| 1.4.3.5.1.090 |  | Install faucet & drain fixtures/plumbing works | 90d | 2012-06-27 | 2012-09-19 | 1.4.3.5.1.080 SS+12.5d | 172.75d | 128.75d | SSH-Construction Manhours [36000 h] | 72,090 | 0.0212951501 |
|  | 4 | **Electrical work** |  | 2012-07-07 | 2012-11-06 |  |  |  |  |  |  |
| 1.4.3.5.1.100 |  | Install electric conduits & fittings | 90d | 2012-07-07 | 2012-09-29 | 1.4.3.5.1.070 SS+35d | 44d | 0d | SSH-Construction Manhours [36000 h] | 54,000 |  |
| 1.4.3.5.1.110 |  | Install cables & wires | 90d | 2012-07-18 | 2012-10-10 | 1.4.3.5.1.100 SS+12.5d | 44d | 0d | SSH-Construction Manhours [72000 h] | 8,999 |  |
| 1.4.3.5.1.120 |  | Install lighting fixtures | 75d | 2012-08-05 | 2012-10-14 | 1.4.3.5.1.110 SS+18.75d | 44d | 0d | SSH-Construction Manhours [72000 h] | 81,000 |  |
| 1.4.3.5.1.130 |  | Install grounding system | 75d | 2012-08-16 | 2012-10-25 | 1.4.3.5.1.120 SS+12.5d | 44d | 0d | SSH-Construction Manhours [43200 h] | 45,000 |  |
| 1.4.3.5.1.140 |  | Testing & commissioing of electric system | 12.5d | 2012-10-25 | 2012-11-06 | 1.4.3.5.1.130, 1.4.3.5.1.015, 1.4.3.5.1.090 SS | 44d |  | SSH-Construction Manhours [72000 h] | 4,500 | 0.0013292853 |
|  | 6 | **Fitness Shelters (7 nos)** |  | 2012-03-17 | 2012-11-12 |  |  |  |  |  |  |
|  | 1 | **Fitness Shelters** |  | 2012-03-17 | 2012-11-12 |  |  |  |  |  |  |
|  | 1 | **Civil work** |  | 2012-03-17 | 2012-07-21 |  |  |  |  |  |  |
| 1.4.3.6.1.010 |  | Excavation for picnic shelters | 60d | 2012-03-17 | 2012-05-10 | 1.4.3.5.1.010 SS | 37.75d | 0d | SSH-Construction Manhours [24000 h]; Excavator [480 h]; Dump Truck [480 h] | 3,500 |  |
| 1.4.3.6.1.015 |  | Backfill/comp for picnic shelters | 50d | 2012-06-04 | 2012-07-21 | 1.4.3.6.1.040 SS+45d | 95.25d | 36.25d | SSH-Construction Manhours [24000 h]; Dump Truck [400 h]; Compactor [400 h] | 5,250 | 0.0015508328 |
|  | 2 | **Structural work** |  | 2012-03-21 | 2012-07-14 |  |  |  |  |  |  |
| 1.4.3.6.1.020 |  | Install lean concrete for reinforced fdns | 75d | 2012-03-21 | 2012-05-30 | 1.4.3.6.1.010 SS+6d | 37.75d | 0d | SSH-Construction Manhours [90000 h] | 4,200 |  |
| 1.4.3.6.1.030 |  | Install reinforced fdns | 87.5d | 2012-04-04 | 2012-06-25 | 1.4.3.6.1.020 SS+15d | 37.75d | 0d | SSH-Construction Manhours [140000 h] | 16,100 |  |
| 1.4.3.6.1.040 |  | Install reinforced roof slab on grade | 87.5d | 2012-04-23 | 2012-07-14 | 1.4.3.6.1.030 SS+20d | 37.75d | 0d | SSH-Construction Manhours [105000 h] | 25,760 | 0.0076094197 |

| ID | WBS | Activity | Duration | Start | Finish | Predecessors | Total float | Free float | Resources | Cost | QTY |
| --- | --- | --- | --- | --- | --- | --- | --- | --- | --- | --- | --- |
|  | 3 | **Architectural work** |  | 2012-05-12 | 2012-10-23 |  |  |  |  |  |  |
| 1.4.3.6.1.050 |  | Install cement based plaster/textured paintn finish | 75d | 2012-05-12 | 2012-07-21 | 1.4.3.6.1.040 SS+20d | 37.75d | 0d | SSH-Construction Manhours [36000 h] | 31,850 |  |
| 1.4.3.6.1.060 |  | Install roofing trellis system | 75d | 2012-05-29 | 2012-08-07 | 1.4.3.6.1.050 SS+18.75d | 37.75d | 0d | SSH-Construction Manhours [60000 h] | 21,560 |  |
| 1.4.3.6.1.070 |  | Install concrete topping, ceramic floor finish | 75d | 2012-06-16 | 2012-08-25 | 1.4.3.6.1.060 SS+18.75d | 37.75d | 0d | SSH-Construction Manhours [60000 h] | 20,930 |  |
| 1.4.3.6.1.080 |  | Install fitness furniture | 75d | 2012-07-19 | 2012-09-27 | 1.4.3.6.1.070 SS+18.75d, 1.3.5.5.030 | 59d | 0d | SSH-Construction Manhours [48000 h] | 58,800 |  |
| 1.4.3.6.1.090 |  | Install aluminium cladding | 75d | 2012-08-06 | 2012-10-15 | 1.4.3.6.1.080 SS+18.75d | 59d | 0d | SSH-Construction Manhours [36000 h] | 42,000 | 0.0124066625 |
| 1.4.3.6.1.100 |  | Install faucet & drain fixtures/plumbing works | 65d | 2012-08-23 | 2012-10-23 | 1.4.3.6.1.090 SS+18.75d, 1.4.3.6.1.015 | 59d | 21.25d | SSH-Construction Manhours [41600 h] | 17,500 |  |
|  | 4 | **Electrical work** |  | 2012-07-18 | 2012-11-12 |  |  |  |  |  |  |
| 1.4.3.6.1.110 |  | Install electric conduits & fittings | 75d | 2012-07-18 | 2012-09-26 | 1.4.3.6.1.070 SS+35d | 37.75d | 0d | SSH-Construction Manhours [60000 h] | 13,700 |  |
| 1.4.3.6.1.120 |  | Install cables & wires | 75d | 2012-08-01 | 2012-10-10 | 1.4.3.6.1.110 SS+15d | 37.75d | 0d | SSH-Construction Manhours [60000 h] | 2,100 |  |
| 1.4.3.6.1.130 |  | Install lighting fixtures | 75d | 2012-08-15 | 2012-10-24 | 1.4.3.6.1.120 SS+15d | 37.75d | 0d | SSH-Construction Manhours [36000 h] | 21,000 |  |
| 1.4.3.6.1.140 |  | Install grounding system | 75d | 2012-08-29 | 2012-11-07 | 1.4.3.6.1.130 SS+15d | 37.75d | 0d | SSH-Construction Manhours [42000 h] | 10,000 |  |
| 1.4.3.6.1.150 |  | Testing & commissioing of electric system | 65d | 2012-09-12 | 2012-11-12 | 1.4.3.6.1.140 SS+15d, 1.4.3.6.1.100 SS | 37.75d |  | SSH-Construction Manhours [52000 h] | 5,750 | 0.0016985312 |
|  | 7 | **Art Work Shelters (8 nos)** |  | 2012-03-17 | 2012-11-07 |  |  |  |  |  |  |
|  | 1 | **Art Work Shelters** |  | 2012-03-17 | 2012-11-07 |  |  |  |  |  |  |
|  | 1 | **Civil work** |  | 2012-03-17 | 2012-07-30 |  |  |  |  |  |  |
| 1.4.3.7.1.010 |  | Excavation for picnic shelters | 60d | 2012-03-17 | 2012-05-10 | 1.4.3.6.1.010 SS | 42.75d | 0d | SSH-Construction Manhours [24000 h]; Excavator [480 h]; Dump Truck [480 h] | 5,900 |  |
| 1.4.3.7.1.015 |  | Backfill/comp for picnic shelters | 60d | 2012-06-04 | 2012-07-30 | 1.4.3.7.1.040 SS+45d | 75.25d | 8.75d | SSH-Construction Manhours [14400 h]; Dump Truck [480 h]; Compactor [480 h] | 3,900 | 0.0011520472 |
|  | 2 | **Structural work** |  | 2012-03-21 | 2012-07-14 |  |  |  |  |  |  |
| 1.4.3.7.1.020 |  | Install lean concrete for reinforced fdns | 62.5d | 2012-03-21 | 2012-05-19 | 1.4.3.7.1.010 SS+6d | 42.75d | 0d | SSH-Construction Manhours [35000 h] | 4,710 |  |
| 1.4.3.7.1.030 |  | Install reinforced fdns | 87.5d | 2012-04-04 | 2012-06-25 | 1.4.3.7.1.020 SS+15d | 42.75d | 0d | SSH-Construction Manhours [140000 h] | 16,250 |  |
| 1.4.3.7.1.040 |  | Install reinforced roof slab on grade | 87.5d | 2012-04-23 | 2012-07-14 | 1.4.3.7.1.030 SS+20d | 42.75d | 0d | SSH-Construction Manhours [80000 h] | 29,440 | 0.0086964796 |
|  | 3 | **Architectural work** |  | 2012-05-12 | 2012-10-16 |  |  |  |  |  |  |
| 1.4.3.7.1.050 |  | Install cement based plaster/textured paintn finish | 75d | 2012-05-12 | 2012-07-21 | 1.4.3.7.1.040 SS+20d | 42.75d | 0d | SSH-Construction Manhours [48000 h] | 32,650 |  |
| 1.4.3.7.1.060 |  | Install roofing trellis system | 75d | 2012-05-29 | 2012-08-07 | 1.4.3.7.1.050 SS+18.75d | 42.75d | 0d | SSH-Construction Manhours [60000 h] | 24,300 |  |
| 1.4.3.7.1.070 |  | Install concrete topping, ceramic floor finish | 75d | 2012-06-16 | 2012-08-25 | 1.4.3.7.1.060 SS+18.75d | 42.75d | 0d | SSH-Construction Manhours [60000 h] | 23,920 |  |
| 1.4.3.7.1.080 |  | Install furniture for art works | 75d | 2012-07-03 | 2012-09-11 | 1.4.3.7.1.070 SS+18.75d | 66.5d | 0d | SSH-Construction Manhours [48000 h] | 93,600 |  |
| 1.4.3.7.1.090 |  | Install aluminium cladding | 75d | 2012-07-21 | 2012-09-29 | 1.4.3.7.1.080 SS+18.75d | 66.5d | 0d | SSH-Construction Manhours [48000 h] | 45,000 | 0.0132928527 |
| 1.4.3.7.1.100 |  | Install faucet & drain fixtures/plumbing works | 75d | 2012-08-07 | 2012-10-16 | 1.4.3.7.1.090 SS+18.75d, 1.4.3.7.1.015 | 66.5d |  | SSH-Construction Manhours [48000 h] | 20,000 |  |

| ID | WBS | Activity | Duration | Start | Finish | Predecessors | Total float | Free float | Resources | Cost | QTY |
| --- | --- | --- | --- | --- | --- | --- | --- | --- | --- | --- | --- |
|  | 4 | **Electrical work** |  | 2012-07-18 | 2012-11-07 |  |  |  |  |  |  |
| 1.4.3.7.1.110 |  | Install electric conduits & fittings | 75d | 2012-07-18 | 2012-09-26 | 1.4.3.7.1.070 SS+35d | 42.75d | 0d | SSH-Construction Manhours [60000 h] | 16,530 |  |
| 1.4.3.7.1.120 |  | Install cables & wires | 75d | 2012-08-01 | 2012-10-10 | 1.4.3.7.1.110 SS+15d | 42.75d | 0d | SSH-Construction Manhours [60000 h] | 2,800 |  |
| 1.4.3.7.1.130 |  | Install lighting fixtures | 75d | 2012-08-15 | 2012-10-24 | 1.4.3.7.1.120 SS+15d | 42.75d | 0d | SSH-Construction Manhours [60000 h] | 28,000 |  |
| 1.4.3.7.1.140 |  | Install grounding system | 75d | 2012-08-29 | 2012-11-07 | 1.4.3.7.1.130 SS+15d | 42.75d |  | SSH-Construction Manhours [42000 h] | 18,000 | 0.0053171411 |
|  | 4 | **PRE-COMMISSIONING WORKS** |  | 2012-01-24 | 2012-12-29 |  |  |  |  |  |  |
|  | 1 | **Submit OSPDP (Operating Spare Parts Data Package** |  | 2012-04-07 | 2012-10-20 |  |  |  |  |  |  |
|  | 1 | **Submit OSPDP** |  | 2012-04-07 | 2012-10-20 |  |  |  |  |  |  |
| 1.4.4.1.010 |  | Complete Submit OSPDP for elect materials | 93.75d | 2012-04-07 | 2012-07-03 | 1.3.2.1.020, 1.4.3.1.1.090, 1.4.3.1.2.090 | 62.75d | 0d | SSH-Construction Manhours [18000 h] | 15,000 |  |
| 1.4.4.1.020 |  | Complete Submit OSPDP for mech materials | 81.25d | 2012-06-04 | 2012-08-19 | 1.4.4.1.010 SS+62.5d | 62.75d | 0d | SSH-Construction Manhours [15000 h] | 10,000 |  |
| 1.4.4.1.030 |  | Complete Submit OSPDP Telecomm materials | 72.5d | 2012-08-13 | 2012-10-20 | 1.4.4.1.020 SS+75d | 62.75d | 0d | SSH-Construction Manhours [16400 h] | 10,000 | 0.0029539673 |
|  | 2 | **Submit O & M (Operating & Maintenance)** |  | 2012-04-07 | 2012-07-21 |  |  |  |  |  |  |
|  | 1 | **Submit O & M** |  | 2012-04-07 | 2012-07-21 |  |  |  |  |  |  |
| 1.4.4.2.010 |  | Submit O&M Documents | 112.5d | 2012-04-07 | 2012-07-21 | 1.4.4.1.010 SS | 67.75d | 0d | SSH-Construction Manhours [27200 h] | 35,000 | 0.0103388854 |
|  | 3 | **Submit Approved Project Record Books** |  | 2012-07-21 | 2012-09-29 |  |  |  |  |  |  |
|  | 1 | **Submit Project Records Books** |  | 2012-07-21 | 2012-09-29 |  |  |  |  |  |  |
| 1.4.4.3.010 |  | Submit approved project record books | 75d | 2012-07-21 | 2012-09-29 | 1.4.4.2.010 | 85.25d | 0d | SSH-Construction Manhours [12000 h] | 35,000 | 0.0103388854 |
|  | 4 | **Submit Pre-Commissioning Activities** |  | 2012-01-24 | 2012-04-02 |  |  |  |  |  |  |
|  | 1 | **Submit Pre-commissioning Activites** |  | 2012-01-24 | 2012-04-02 |  |  |  |  |  |  |
| 1.4.4.4.010 |  | Submit pre-commissioing activities for all facilities | 75d | 2012-01-24 | 2012-04-02 | 1.2.6.200, 1.2.8.010 SS | 99.25d | 61d | SSH-Construction Manhours [19200 h] | 75,000 | 0.0221547545 |
|  | 5 | **Submit Red Lined Drawings** |  | 2012-10-21 | 2012-11-19 |  |  |  |  |  |  |
|  | 1 | **Submit red lined drawings** |  | 2012-10-21 | 2012-11-19 |  |  |  |  |  |  |
| 1.4.4.5.010 |  | Submit complete red lined as built drawings-civil | 31.25d | 2012-10-21 | 2012-11-18 | 1.4.4.2.010 SS+37.5d, 1.4.3.1.1.570, 1.4.3.1.2.560, 1.4.3.2.1.1340, M2.10, 1.4.3.1.2.570, M2.17, M2.14 | 30d | 0d | SSH-Construction Manhours [25000 h] | 30,000 |  |
| 1.4.4.5.020 |  | Submit complete red lined as built drawings-mech | 31.25d | 2012-10-21 | 2012-11-18 | 1.4.4.5.010 SS, 1.4.3.1.2.560, 1.4.3.1.1.570, 1.4.3.2.1.1340, 1.4.3.1.2.570, M2.10, M2.17, M2.14 | 30d | 0d | SSH-Construction Manhours [25000 h] | 30,000 |  |
| 1.4.4.5.030 |  | Submit complete red lined as built drawings-elect | 31.25d | 2012-10-21 | 2012-11-18 | 1.4.4.5.020 SS, 1.4.2.7.4.010, 1.4.2.7.4.020, 1.4.2.7.4.040, 1.4.2.7.4.050, 1.4.2.7.4.070, 1.4.2.7.4.072, 1.4.2.7.4.150, 1.4.2.7.4.152, 1.4.2.7.4.190, 1.4.2.7.4.192, 1.4.2.7.4.210, 1.4.2.7.4.212, 1.4.2.7.4.230 SS, 1.4.2.7.4.232 SS, 1.4.2.7.4.250 SS, 1.4.2.7.4.252 SS, 1.4.2.7.4.270 SS, 1.4.2.7.4.272 SS, 1.4.3.1.2.560, 1.4.3.1.1.570, 1.4.3.2.1.1340, 1.4.3.1.2.570, M2.10, M2.17, M2.14 | 30d | 0d | SSH-Construction Manhours [25000 h] | 30,000 |  |
| 1.4.4.5.040 |  | Submit complete red lined as built drawings-telecomm | 32.5d | 2012-10-21 | 2012-11-19 | 1.4.4.5.030 SS, 1.4.3.1.2.560, 1.4.3.1.1.570, 1.4.3.2.1.1340, 1.4.3.1.2.570, M2.10, M2.17, M2.14 | 30d | 0d | SSH-Construction Manhours [26000 h] | 30,000 | 0.0088619018 |

| ID | WBS | Activity | Duration | Start | Finish | Predecessors | Total float | Resources | Cost | QTY |
| --- | --- | --- | --- | --- | --- | --- | --- | --- | --- | --- |
|  | 7 | **MCC - Mechanical Completion Certificate** |  | 2012-12-18 | 2012-12-29 |  |  |  |  |  |
|  | 1 | **MCC** |  | 2012-12-18 | 2012-12-29 |  |  |  |  |  |
| 1.4.4.6.010 |  | Mechanical Completion of all works -MCC | 12.5d | 2012-12-18 | 2012-12-29 | 1.4.4.5.040, 1.4.4.3.010, 1.4.4.4.010, M2.20, M2.19, M2.17, M2.16, M2.15, M2.18, M2.09, M2.14, 1.4.3.1.1.780, M2.10, M2.11, M2.12, M2.13, Z1.1060, 1.4.2.5.3.110, 1.4.2.5.4.050, 1.4.3.1.1.570, 1.4.2.5.6.020D, 1.4.2.6.170, 1.4.2.6.120, 1.4.3.6.1.150, 1.4.3.7.1.140, 1.4.3.7.1.100, 1.4.3.5.1.140, 1.4.2.5.6.010D, 1.4.3.1.2.570 | 0d | SSH-Construction Manhours [100000 h] | 200,000 | 0.0590793454 |
|  | 5 | **DEMOBILIZATION** |  | 2012-12-30 | 2013-06-29 |  |  |  |  |  |
|  | 1 | **Demobilization** |  | 2012-12-30 | 2013-06-29 |  |  |  |  |  |
|  | 1 | **Demobilization** |  | 2012-12-30 | 2013-06-29 |  |  |  |  |  |
| 1.4.5.1.010 |  | Remove Temporary gates & Jersey Barriers | 112.5d | 2012-12-30 | 2013-04-13 | 1.4.4.6.010 | 0d | SSH-Construction Manhours [360000 h]; Fork-Lifter [900 h]; Crane [900 h]; Trailer [900 h] | 1,200,000 |  |
| 1.4.5.1.020 |  | Touch up of roads according to the existing roads | 37.5d | 2013-04-14 | 2013-05-18 | 1.4.5.1.010, M2.22 | 0d | SSH-Construction Manhours [60000 h]; Asphalt Machine [300 h] | 800,000 |  |
| 1.4.5.1.030 |  | Removal of temporary offices | 25d | 2013-05-19 | 2013-06-10 | 1.4.5.1.020 | 0d | SSH-Construction Manhours [30000 h]; Crane [200 h]; Trailer [200 h] | 250,000 |  |
| 1.4.5.1.040 |  | Demobilization of equipments & manpower | 20d | 2013-06-11 | 2013-06-29 | 1.4.5.1.030 | 0d | SSH-Construction Manhours [25500 h]; Trailer [160 h] | 250,000 |  |
