# KAUST RESEARCH PARK INFRASTRUCTURE ZONE 3 & 4

Schedule from Primavera P6, 2016-08-09 to 2018-01-30, data date 2016-08-09, costs in SR.
Must finish by 2018-01-30

## Calendars

- RPI 2 - Thuwal (6D + Holidays): Mon-Thu 07:00-17:00; Fri off; Sat-Sun 07:00-17:00. Exceptions (off unless hours are given): 2016-09-10 08:00-16:00, 2016-09-11 to 2016-09-14, 2017-06-26 to 2017-06-29, 2017-08-31, 2017-09-02 to 2017-09-04, 2017-09-23.
- RPI 2 - Thuwal (7 days Calendar): Mon-Sun 07:00-17:00.

## Resources

| Resource | Group | Unit |
| --- | --- | --- |
| Common Labor / Helper | labor |  |
| Operator - Mobile Crane | labor |  |
| Driver - Flat Bed Trailer | labor |  |
| Mobile Crane ( 25-60 Ton) | equipment |  |
| Flat Bed Trailer | equipment |  |
| DI Flanged Short Pipes, DI Tee, Puddle Sleeves, Nuts & Bolts, Gasket | material | ea |
| Code Blue LV Cables | material | Lm |
| UPVC Tee & Elbows | material | ea |
| GI Steel Ladders | material | ea |
| Cholorination Skid | material | ea |
| UPVC Pipes & Fittings including Blind Flanges | material | Lm |
| CS Pipe Sleeves & DI Fittings for Valve Boxes | material | ea |
| Non-Metalic Inscet Screen 150 mm dia. | material | ea |
| Direct Buried Valves & Gate Valves (200 mm dia.) for Irrigation | material | ea |
| 3/4" Rigid Conduits PVC Coated | material | Lm |
| Direct Buried Irrigation Wires | material | Lm |
| LV Cables | material | Lm |
| PVC Conduits (Walkway & Landscape Lights | material | Lm |
| Traffic Signage | material | ea |
| Client Offices (including AC) | material | LS |
| Furniture for Client Office | material | LS |
| Parking Shades (10 Parkings) for Client Office | material | ea |
| IT Req., Office Supplies & Consumables (Client Office) | material | LS |
| Masonry Block & Accessories | material | Sqm |
| External Building Signage | material | ea |
| Internal Signage & Tags | material | ea |
| Paint - Epoxy Coating | material | Sqm |
| Paint for Walls & Ceiling (Internal / External) | material | Sqm |
| Wooden Trellis & Canopy | material | Sqm |
| Chain Link Fence & Gate | material | Lm |
| Pre-cast Concrete Fence (for Lift Stations) | material | Lm |
| Steel Gate for Lift Stations | material | ea |
| Water Proofing & Roofing System | material | Sqm |
| FRP - Ladders, Covers & Gratting | material | ea |
| Lifting Hoist for Lift Stations | material | ea |
| Door Hardware & Accessories | material | LS |
| Sanitary Plumbing Fixtures & Toilet Accessories | material | ea |
| Snack Bar Counter & Cabinet | material | ea |
| Aluminum Windows | material | ea |
| Glass Blocks (for Toilets) | material | Sqm |
| Gypum Board & Accessories (Toilets & Snack Bars) | material | Sqm |
| Mosaic Tiles (for Toilets) | material | Sqm |
| Quarry Tiles (for Toilets) | material | Sqm |
| Avonite Counter top with Cabinet (Toilets) | material | LS |
| Odor Control System Accessories | material | LS |
| HVAC Ducts, Grills and Accessories | material | LS |
| FRP Manholes & Lamination | material | ea |
| Window Type AC | material | ea |
| Fire Extinguishers | material | ea |
| Package Type AC | material | ea |
| DDC Panels (HVAC for Lift Stations) | material | ea |
| Fire Alarm System | material | LS |
| SACS System | material | LS |
| CCTV System | material | LS |
| IP Phone System | material | LS |
| Steel Pipes Fusion Coated (for Road - 5 & Road - 1 Crossing) | material | Lm |
| Junction Boxes - Explosion Proof (for Lift Stations) | material | ea |
| Electrical Switches & Panel NEMA 4X (for Lift Stations) | material | ea |
| Excavator | equipment |  |
| Loader | equipment |  |
| Forklift | equipment |  |
| Dump Truck | equipment |  |
| Grader | equipment |  |
| Bobcat | equipment |  |
| Concrete Transit Mixers | equipment |  |
| Concrete Pump | equipment |  |
| Asphalt Paver | equipment |  |
| Asphalt Compactor / Roller | equipment |  |
| Roller-Compactor (2~10 Ton) | equipment |  |
| Roller-Compactor (25 Ton) | equipment |  |
| Plate Compactor | equipment |  |
| Vibrators | equipment |  |
| Water Tanker | equipment |  |
| Fuel Tanker | equipment |  |
| Toilet Partitions (Phenolic 19 mm thick) | material | Sqm |
| Air-Compressor 300/900 CFM + Hummer | equipment |  |
| Dewatering Pumps | equipment |  |
| Tower Light | equipment |  |
| Boom Truck (15 Ton) | equipment |  |
| Manlift (Boom Truck) | equipment |  |
| JCB | equipment |  |
| Steel Fixer | labor |  |
| Shuttering Carpenter | labor |  |
| Concrete Mason | labor |  |
| Plumber | labor |  |
| Electrician | labor |  |
| Mechanical Technician | labor |  |
| Welder | labor |  |
| LC Crew | labor |  |
| Fence Crew - Lift Station | labor |  |
| Wood Works Crew | labor |  |
| Gypsum Walls & Ceiling Crew | labor |  |
| Road Works Crew | labor |  |
| Finishing Work Crew | labor |  |
| Hardscape Crew | labor |  |
| Soft Landscaping Crew | labor |  |
| Specialist Works Crew | labor |  |
| Operator - Excavator | labor |  |
| Operator - Loader | labor |  |
| Operator - Forklift | labor |  |
| Driver - Dump Truck | labor |  |
| Scaffolder | labor |  |
| Block Mason | labor |  |
| Plaster Mason | labor |  |
| Tiling Crew | labor |  |
| Painter | labor |  |
| RTR Pipe Crew | labor |  |
| Water Proofing Crew | labor |  |
| HVAC Crew | labor |  |
| Operator - Grader | labor |  |
| Operator - Bobcat | labor |  |
| Driver - Conc. Transit Mixers | labor |  |
| Operator - Concrete Pump | labor |  |
| Operator - Asphalt Paver | labor |  |
| Operator - Asphalt Compactor / Roller | labor |  |
| Operator - Roller-Compactor (2~10 Ton) | labor |  |
| Operator - Roller (25 Ton) | labor |  |
| Driver - Water Tanker | labor |  |
| Driver - Fuel Tanker | labor |  |
| Operator - Boom Truck (15 Ton) | labor |  |
| Operator - Manlift (Boom Truck) | labor |  |
| Operator - JCB | labor |  |
| Drivers Light Duty | labor |  |
| FOC - Copper Cables | material | Lm |
| Copper Splices | material | ea |
| Co-Axial Cables | material | Lm |
| Splicing FOC | material | ea |
| Code Blue Pedestal | material | ea |
| Code Blue LV Cables | material | Lm |
| Sand for Backfilling | material | Cum |
| Warning Tapes | material | Lm |
| Red Tiles | material | ea |
| Ground Cable and Accessories | material | Lm |
| Manhole Frame & Covers | material | ea |
| PVC Sub-ducts | material | Lm |
| Sub-ducts Plugging | material | ea |
| Geogrid | material | Sqm |
| Geotextile Fabric | material | Sqm |
| Sub-base (Class -B) | material | Cum |
| Aggregate Base Course | material | Sqm |
| Asphalt | material | Sqm |
| Concrete Curb & Gutter | material | Lm |
| Polyethene Sheet | material | Sqm |
| Bituminus Paint | material | Sqm |
| Ready Mix Concrete | material | m³ |
| Steel Reinforcement | material | kg |
| Selected Fill (Backfilling) | material | Cum |
| Traffic Signage | material | ea |
| Road Marking Paint | material | Sqm |
| Steel Pipe Bollards | material | ea |
| Bench & Picnic Tables | material | ea |
| Drinking Fountains | material | ea |
| BBQ Grill with cover | material | ea |
| Hand wash | material | ea |
| Trash Receptacle | material | ea |
| MV Cables | material | Lm |
| MV Cables Splicing & Repairing Kits | material | ea |
| PVC Piles including Spacers | material | Lm |
| 10 M High Lighting Poles | material | ea |
| Ligting Fixtures | material | ea |
| Wiring Devices | material | ea |
| Cable Markers | material | ea |
| MCC Panels | material | ea |
| Disconnect Switches | material | ea |
| PVC Coated Conduits including Accessories | material | Lm |
| Instrumentation Materials | material | LS |
| Concrete Foundation | material | ea |
| LV & MV Cable Accessories | material | Lm |
| Exhaust Fan | material | ea |
| UTP Cables | material | Lm |
| Data Cabinet with Components | material | ea |
| Telecom Enclosure | material | ea |
| Telephone Outlet, Conduiting, Cabling & Accessories | material | ea |
| FOC - Fiber Optic Cables | material | Lm |
| Splice Closure | material | ea |
| Adtran 850 | material | ea |
| TYPE "L" DOUBLE SIDED MDF 9' X 10 VERTICAL | material | ea |
| TV Wall Brackets & Accessories | material | ea |
| Code Blue Pedestals | material | ea |
| Palm Trees | material | ea |
| Washing Tonia Robusta - Trees | material | ea |
| Jacaranda - Trees | material | ea |
| Cassia Fistula - Trees | material | ea |
| Albizia Julibrissin - Trees | material | ea |
| Chamaerops Humilis - Trees | material | ea |
| Cycas Revolute - Plant | material | ea |
| Shurbs | material | ea |
| Ground Covers | material | ea |
| Gravel & Gravel Mulch, Gravel N0.4 PEA | material | Sqm |
| Play Ground Sand & Sand Fill | material | Sqm |
| Selected Fill | material | Cum |
| Precast Concrete Pavers, Interlocking Paver | material | Sqm |
| Curb (Concrete Edger), Curb & Gutter | material | Lm |
| Ready Mix Concrete | material | Cum |
| Rubber Tiles (Rubber Tile Surface) | material | Sqm |
| Protective Railing | material | Lm |
| Steel Bicycle Rack Assembly | material | Lm |
| Paint for Marking & Road Marking | material | Sqm |
| Stainless Steel Hand Rails | material | Lm |
| Bermuda Turf Sod / Grass | material | Sqm |
| Galvanized Pipe Railing covered with Rubber Guards 50 mm dia HD | material | Lm |
| Precast Round Crested Concrete Weir | material | Lm |
| Play Ground Equipment Accessories | material | LS |
| Fitness Equipment Accessories | material | LS |
| RTR Pipes & Fittings | material | Lm |
| Fire Hydrant including Break Check Valves | material | ea |
| Gate Valves Direct Buried with Extension Spindle & Surface Box | material | ea |
| Metallic Flanges, Pipes & Fittings (for Fire Hydrants) | material | Set |
| Guard Posts for Fire Hydrants | material | ea |
| Dismantling Joints - Valve Box Fittings | material | ea |
| Gate Valves, Butterfly Valves, Drain Valves, Air Release Valves | material | ea |
| Shurbs (m2) | material | Sqm |
| Ground Covers (m2) | material | Sqm |

## Schedule

| ID | WBS | Activity | Type | Duration | Start | Finish | Predecessors | Total float | Free float | Calendar | Wajid | RPI_P2 - PHASE |
| --- | --- | --- | --- | --- | --- | --- | --- | --- | --- | --- | --- | --- |
|  | 1 | **GENERAL** |  |  | 2016-08-09 | 2018-01-30 |  |  |  |  |  |  |
|  | 1 | **GENERAL** |  |  | 2016-08-09 | 2018-01-30 |  |  |  |  |  |  |
| GE-GE-GE-GE-GE-0010 |  | Project Start | milestone | 0d | 2016-08-09 | 2016-08-09 |  | 0d |  | RPI 2 - Thuwal (7 days Calendar) | OK | GEN |
| GE-GE-GE-GE-GE-0020 |  | Project Finish | milestone | 0d | 2018-01-30 | 2018-01-30 | GE-ML-GE-GE-GE-0020 FS+470d, GE-MS-ENG-ENG-0010, GE-DWG-ENG-ENG-0050, CON-CON-CON-CON-0020, GE-ML-GE-GE-GE-0190, GE-ML-GE-GE-GE-0180, GE-CO-DL-GE-GE-0080, CO-PD-DM-DM-GE-0010, CO-PD-PC-MN-GE-0010, CO-PD-PC-PC-GE-0070, CO-PD-PC-PC-GE-0080, CO-MO-SE-GE-GE-0180, GE-ML-GE-GE-GE-0130 FS+80d, GE-ML-GE-GE-GE-0140 FS+60d, CO-PD-DM-RD-GE-0010, CO-PD-DM-DM-GE-0020, CO-PD-DM-DM-GE-0030, CO-PD-DM-DM-GE-0040, GE-ML-GE-GE-GE-0070 FS+200d, GE-ML-GE-GE-GE-0100 FS+107d, GE-ML-GE-GE-GE-0150 FS+60d, GE-CO-DL-GE-GE-0100, CO-PD-DM-PT-GE-0010, CO-PD-PC-SP-GE-0010, CO-PD-PC-PC-GE-0030, GE-ML-GE-GE-GE-0080 FS+140d, GE-CO-DL-GE-GE-0040, PROC-GE-GE-GE-0020, CO-PD-DM-DM-GE-0050, GE-ML-GE-GE-GE-0040 FS+450d, GE-ML-GE-GE-GE-0050 FS+350d, GE-ML-GE-GE-GE-0120 FS+107d, GE-ML-GE-GE-GE-0160 FS+60d, GE-CO-DL-GE-GE-0120, GE-CO-DL-GE-GE-0130, CO-PD-DM-JB-GE-0010, CO-PD-DM-AB-GE-0010, CO-PD-PC-PL-GE-0010, CO-PD-PC-PC-GE-0020, GE-ML-GE-GE-GE-0030 FS+450d, GE-ML-GE-GE-GE-0060 FS+350d, GE-ML-GE-GE-GE-0110 FS+107d, GE-CO-DL-GE-GE-0050, GE-CO-DL-GE-GE-0060, GE-CO-DL-GE-GE-0070, GE-CO-DL-GE-GE-0090, CO-PD-PC-PC-GE-0010, GE-ML-GE-GE-GE-0010, GE-ML-GE-GE-GE-0090 FS+140d, GE-ML-GE-GE-GE-0170 FS+30d, CO-PD-DM-RB-GE-0010, CO-PD-PC-PC-GE-0040 | 0d |  | RPI 2 - Thuwal (7 days Calendar) | OK | GEN |
|  | 2 | **CLIENT DELIVERABLES** |  |  | 2016-08-09 | 2016-08-09 |  |  |  |  |  |  |
| GE-CL-DL-GE-GE-0010 |  | Notice to Proceed | milestone | 0d | 2016-08-09 | 2016-08-09 | GE-GE-GE-GE-GE-0010 | 0d |  | RPI 2 - Thuwal (7 days Calendar) | OK | GEN |
| GE-CL-DL-GE-GE-0020 |  | Site Handing Over - (ZONE - 1, 2 , 3 & 4) |  | 1d | 2016-08-09 | 2016-08-09 | GE-CL-DL-GE-GE-0010 | 0d |  | RPI 2 - Thuwal (7 days Calendar) | OK | GEN |
| GE-CL-DL-GE-GE-0060 |  | Handing Over Area - Material Storage Area (Block - 6 @ ZONE - 3) |  | 1d | 2016-08-09 | 2016-08-09 | GE-CL-DL-GE-GE-0010 | 39.8d | 10d | RPI 2 - Thuwal (7 days Calendar) | OK | GEN |
| GE-CL-DL-GE-GE-0070 |  | Saudi Aramco Supplied Materials as per Sch - G |  | 1d | 2016-08-09 | 2016-08-09 | GE-CL-DL-GE-GE-0010 | 39.8d | 10d | RPI 2 - Thuwal (7 days Calendar) | OK | GEN |
| GE-CL-DL-GE-GE-0080 |  | Issuance of IFC Drawings |  | 1d | 2016-08-09 | 2016-08-09 | GE-CL-DL-GE-GE-0010 | 48d | 0d | RPI 2 - Thuwal (7 days Calendar) | OK | GEN |
|  | 3 | **CONTRACT DELIVERABLES** |  |  | 2016-08-09 | 2016-09-07 |  |  |  |  |  |  |
| GE-CO-DL-GE-GE-0010 |  | Project Execution Plan (PEP) - (within 30 Days) |  | 30d | 2016-08-09 | 2016-09-07 | GE-ML-GE-GE-GE-0000 | 20d | 0d | RPI 2 - Thuwal (7 days Calendar) | OK | GEN |
| GE-CO-DL-GE-GE-0020 |  | Procurement Plan (within 30 Days) |  | 30d | 2016-08-09 | 2016-09-07 | GE-ML-GE-GE-GE-0000 | 20d | 0d | RPI 2 - Thuwal (7 days Calendar) | OK | GEN |
| GE-CO-DL-GE-GE-0030 |  | Work Scheule (within 30 Days) |  | 30d | 2016-08-09 | 2016-09-07 | GE-ML-GE-GE-GE-0000 | 20d | 0d | RPI 2 - Thuwal (7 days Calendar) | OK | GEN |
| GE-CO-DL-GE-GE-0040 |  | Interdependency Schedule (within 30 Days) |  | 30d | 2016-08-09 | 2016-09-07 | GE-ML-GE-GE-GE-0000 | 20d | 0d | RPI 2 - Thuwal (7 days Calendar) | OK | GEN |
| GE-CO-DL-GE-GE-0050 |  | Document Distribution Matrix (within 30 Days) |  | 30d | 2016-08-09 | 2016-09-07 | GE-ML-GE-GE-GE-0000 | 20d | 0d | RPI 2 - Thuwal (7 days Calendar) | OK | GEN |
| GE-CO-DL-GE-GE-0060 |  | Saudization & Training Plan (within 30 Days) |  | 30d | 2016-08-09 | 2016-09-07 | GE-ML-GE-GE-GE-0000 | 20d | 0d | RPI 2 - Thuwal (7 days Calendar) | OK | GEN |
| GE-CO-DL-GE-GE-0070 |  | Personnel Organization Chart |  | 30d | 2016-08-09 | 2016-09-07 | GE-ML-GE-GE-GE-0000 | 20d | 0d | RPI 2 - Thuwal (7 days Calendar) | OK | GEN |
| GE-CO-DL-GE-GE-0080 |  | CSSP - Conctractor Site Safety Program (within 15 working Days) |  | 15d | 2016-08-09 | 2016-08-23 | GE-ML-GE-GE-GE-0000 | 35d | 15d | RPI 2 - Thuwal (7 days Calendar) | OK | GEN |
| GE-CO-DL-GE-GE-0090 |  | Hazardous Identification Plan (within 15 working Days) |  | 15d | 2016-08-09 | 2016-08-23 | GE-ML-GE-GE-GE-0000 | 35d | 15d | RPI 2 - Thuwal (7 days Calendar) | OK | GEN |
| GE-CO-DL-GE-GE-0100 |  | Envoirnmental Management Program (within 15 working Days) |  | 15d | 2016-08-09 | 2016-08-23 | GE-ML-GE-GE-GE-0000 | 35d | 15d | RPI 2 - Thuwal (7 days Calendar) | OK | GEN |
| GE-CO-DL-GE-GE-0110 |  | Procurement Procedure (within 30 Days) |  | 30d | 2016-08-09 | 2016-09-07 | GE-ML-GE-GE-GE-0000 | 20d | 0d | RPI 2 - Thuwal (7 days Calendar) | OK | GEN |
| GE-CO-DL-GE-GE-0120 |  | Quality Plan & Inspection Test Plan (within 21 days) |  | 21d | 2016-08-09 | 2016-08-29 | GE-ML-GE-GE-GE-0000 | 29d | 9d | RPI 2 - Thuwal (7 days Calendar) | OK | GEN |
| GE-CO-DL-GE-GE-0130 |  | Completion of Plans & Documents | milestone | 0d | 2016-09-07 | 2016-09-07 | GE-CO-DL-GE-GE-0120, GE-CO-DL-GE-GE-0100, GE-CO-DL-GE-GE-0010, GE-CO-DL-GE-GE-0090, GE-CO-DL-GE-GE-0110, GE-CO-DL-GE-GE-0040, GE-CO-DL-GE-GE-0050, GE-CO-DL-GE-GE-0080, GE-CO-DL-GE-GE-0020, GE-CO-DL-GE-GE-0030, GE-CO-DL-GE-GE-0070, GE-CO-DL-GE-GE-0060 | 20d | 0d | RPI 2 - Thuwal (7 days Calendar) |  |  |

| ID | WBS | Activity | Type | Duration | Start | Finish | Predecessors | Total float | Free float | Calendar | Wajid | RPI_P2 - PHASE |
| --- | --- | --- | --- | --- | --- | --- | --- | --- | --- | --- | --- | --- |
|  | 4 | **WORK & SECURITY PERMITS** |  |  | 2016-08-09 | 2016-08-14 |  |  |  |  |  |  |
| GE-W-SEC-GE-GE-0010 |  | Work & Security Permits for ZONE- 1, 2, 3 & 4 Areas |  | 5d | 2016-08-09 | 2016-08-14 | GE-GE-GE-GE-GE-0010 | 25.6d | 0d |  | OK | GEN |
|  | 2 | **MILESTONES** |  |  | 2016-08-09 | 2018-01-30 |  |  |  |  |  |  |
| GE-ML-GE-GE-GE-0000 |  | Start of Project (Notice to Proceed) | milestone | 0d | 2016-08-09 | 2016-08-09 | GE-GE-GE-GE-GE-0010 | 20d | 0d | RPI 2 - Thuwal (7 days Calendar) | NOT | GEN |
| GE-ML-GE-GE-GE-0010 |  | Submission of Project Execution Plan (PEP), Procurement Plan & Work Schedule | milestone | 0d | 2016-09-07 | 2016-09-07 | GE-CO-DL-GE-GE-0010, GE-CO-DL-GE-GE-0130, CON-PEP-MOB-MOB-20, GE-CO-DL-GE-GE-0030, GE-CO-DL-GE-GE-0010 FF, CON-SCH-MOB-MOB-20, GE-CO-DL-GE-GE-0020, GE-ML-GE-GE-GE-0000 | 40d | 14.4d | RPI 2 - Thuwal (7 days Calendar) | NOT | GEN |
| GE-ML-GE-GE-GE-0020 |  | Complete the relocation of storehouse along with material at Block-6 and prepare area for HO | milestone | 0d | 2016-09-22 | 2016-09-22 | GE-UTIL-REL-GE-0270, GE-UTIL-REL-GE-0020, GE-UTIL-REL-GE-0250, GE-ML-GE-GE-GE-0000, GE-UTIL-REL-GE-0150, GE-ML-GE-GE-GE-0010, GE-UTIL-REL-GE-0100 | 25.6d | 13.8d | RPI 2 - Thuwal (7 days Calendar) | NOT | GEN |
| GE-ML-GE-GE-GE-0030 |  | Complete Site Mobilization (Incl. all Temp. Construction Facilities for Start of Construction) | milestone | 0d | 2016-10-06 | 2016-10-06 | GE-ML-GE-GE-GE-0000, CON-CLT-MOB-MOB-10, CON-GEN-MOB-MOB-100, GE-ML-GE-GE-GE-0020 | 31.8d | 0d | RPI 2 - Thuwal (7 days Calendar) | NOT | GEN |
| GE-ML-GE-GE-GE-0040 |  | Complete Site Preparation | milestone | 0d | 2016-10-06 | 2016-10-06 | GE-ML-GE-GE-GE-0000, GE-SIT-PREP-GE-0030, GE-SIT-PREP-GE-0010, GE-ML-GE-GE-GE-0030, CON-PEP-MOB-MOB-30, CON-SCH-MOB-MOB-30, GE-SIT-PREP-GE-0020 | 31.8d |  | RPI 2 - Thuwal (7 days Calendar) | NOT | GEN |
| GE-ML-GE-GE-GE-0050 |  | Complete Pre-commissioning & testing for existing works executed by prev. Contractor at Zone 3 & 4 | milestone | 0d | 2017-01-05 | 2017-01-05 | GE-MS-ENG-ENG-0040, GE-ML-GE-GE-GE-0040, CON-Z3-UT-IRG-PL-040, CON-Z3-UT-PW-PL-0270, GE-ML-GE-GE-GE-0000, GE-MS-ENG-ENG-0050, GE-MS-ENG-ENG-0010, CON-SCH-MOB-MOB-30, GE-MS-ENG-ENG-0020, GE-MS-ENG-ENG-0030, CON-PEP-MOB-MOB-30, CON-Z3-UT-ELE-TC-010, CON-Z3-UTIL-SEA-060 | 40.8d | 0d | RPI 2 - Thuwal (7 days Calendar) | NOT | GEN |
| GE-ML-GE-GE-GE-0060 |  | Award all PO's for Major and Bulk Material | milestone | 0d | 2017-01-05 | 2017-01-05 | PR-MT-Z1-LC-06-0050, PR-MT-Z1-LC-05-0050, PR-MT-Z1-LC-10-0050, PR-MT-Z1-LC-13-0050, PR-MT-Z1-LC-01-0050, PR-MT-Z1-LC-12-0050, PR-MT-Z1-LC-08-0050, PR-MT-Z1-LC-03-0050, PR-Z3-CW-RW-17-0050, PR-MT-Z1-LC-09-0050, PR-MT-Z1-LC-11-0050, PR-Z3-CW-RW-19-0050, GE-ML-GE-GE-GE-0000, GE-ML-GE-GE-GE-0050, PR-MT-Z1-LC-07-0050, PR-MT-Z1-LC-04-0050, PR-MT-Z1-LC-14-0050, PR-Z3-CW-RW-16-0050 | 40.8d |  | RPI 2 - Thuwal (7 days Calendar) | NOT | GEN |
| GE-ML-GE-GE-GE-0070 |  | Complete Potable Water / Fire Water Supply and Distribution System | milestone | 0d | 2017-06-04 | 2017-06-04 | GE-ML-GE-GE-GE-0060, CON-Z4-UT-PW-VC-5770, CON-Z3-UT-PW-PL-790, GE-ML-GE-GE-GE-0000, CON-SZ3-SS-TIE-60 | 40.8d |  | RPI 2 - Thuwal (7 days Calendar) | NOT | GEN |
| GE-ML-GE-GE-GE-0080 |  | Complete Sea Water Distribution System | milestone | 0d | 2017-08-03 | 2017-08-03 | CON-Z4-UT-SEA-PL-180, GE-ML-GE-GE-GE-0000, CON-Z3-UT-SW-VC-8440, GE-ML-GE-GE-GE-0070, CON-Z3-UT-SEA-PL-400, CON-SZ3-SEA-TIE-100, CON-Z4-UT-SW-WD11-95 | 40.8d |  | RPI 2 - Thuwal (7 days Calendar) | NOT | GEN |
| GE-ML-GE-GE-GE-0090 |  | Complete Sanitary Sewage System (Gravity, Force Main Lines and Lift Stations) | milestone | 0d | 2017-08-03 | 2017-08-03 | RPI-Z3-LS10-TC-0060, GE-ML-GE-GE-GE-0000, RPI-Z3-LS11-TC-0060, CON-Z4-LS9-TC-0060, CON-Z4-UT-SS-VC-0140, CON-Z3-UT-SS-VC-1260, CON-SZ3-SS-TIE-0040, CON-Z4-UT-SEW-MH-070, CON-Z4-UT-FM-PL-220 | 40.2d |  | RPI 2 - Thuwal (7 days Calendar) | NOT | GEN |
| GE-ML-GE-GE-GE-0100 |  | Complete All Roads (Incl. Walkways, Curbs, Gutters, Street & Landscaping Lighting, Signs & Pavement Markings) | milestone | 0d | 2017-08-03 | 2017-08-03 | CON-Z3-UTI-RD-R4-120, CON-Z4-UTI-RD-RE-010, CON-Z3-UTI-RD-R5-480, CON-Z3-UTI-RD-R5-620, CON-Z3-LS-PT-0030, CON-Z3-UTI-RD-GE-010, CON-Z3-UTI-RD-R5-340, CON-Z3-UTI-RD-R1-470, GE-ML-GE-GE-GE-0000, CON-Z3-UTI-RD-R5-170 | 73.2d | 26.4d | RPI 2 - Thuwal (7 days Calendar) | NOT | GEN |
| GE-ML-GE-GE-GE-0110 |  | Complete Irrigation System | milestone | 0d | 2017-08-30 | 2017-08-30 | GE-ML-GE-GE-GE-0100, CON-Z3-UT-IRG-GE-050, GE-ML-GE-GE-GE-0000, CON-Z3-UT-IRG-PL-400, CON-Z3-UT-IRG-PL-340, CON-Z4-UT-IRG-PL-310, CON-Z4-UT-IRG-PL-120 | 46.8d |  | RPI 2 - Thuwal (7 days Calendar) | NOT | GEN |
| GE-ML-GE-GE-GE-0120 |  | Complete Electrical Power Distribution System | milestone | 0d | 2017-08-30 | 2017-08-30 | CONC-Z3-UTIL-ELE-840, CONC-Z4-UTIL-SL-010, CON-Z3-UTI-EL-SL-400, GE-ML-GE-GE-GE-0000, CONC-Z4-UTIL-ELE-120, CONC-Z4-UTIL-ELE-130, CONC-Z4-UTIL-ELE-140 | 46d | 32.2d | RPI 2 - Thuwal (7 days Calendar) | NOT | GEN |
| GE-ML-GE-GE-GE-0130 |  | Complete Storm Water Drainage System | milestone | 0d | 2017-10-02 | 2017-10-02 | CON-Z3-UTI-CUL-080, GE-ML-GE-GE-GE-0000, GE-ML-GE-GE-GE-0120, CON-Z4-POND-05-0050, CON-Z3-POND-06-0050 | 40.8d |  | RPI 2 - Thuwal (7 days Calendar) | NOT | GEN |
| GE-ML-GE-GE-GE-0140 |  | Complete Telecummunication & Security System | milestone | 0d | 2017-11-01 | 2017-11-01 | CON-Z3-UTIL-COM-1090, GE-ML-GE-GE-GE-0000, CON-Z4-UTIL-COM-0400, CON-Z1-UTIL-COM-370, CON-Z1-UTIL-COM-160, CON-Z1-UTIL-COM-0040, CON-Z4-UTIL-COM-560, CON-Z1-UTIL-COM-360 | 0.4d | 0.2d | RPI 2 - Thuwal (7 days Calendar) | OK | GEN |
| GE-ML-GE-GE-GE-0150 |  | Complete Public Realm Area (Incl. Toilets, Snack Booths, Pinic, Fitness & Art Work Shelters, Soft & Hard Scaping) | milestone | 0d | 2017-11-01 | 2017-11-01 | GE-ML-GE-GE-GE-0000, CON-Z3-FS-06-TC-0040, CON-Z3-FS-07-TC-270, CON-Z3-FS-07-TC-310, CON-Z3-Tl01-TC-0050, CON-Z3-PS-01-TC-0030, GE-ML-GE-GE-GE-0140, CON-Z3-AS-01-TC-0040, CON-Z3-PS-02-TC-0030, CON-Z3-PS-04-TC-0030, CON-Z3-FS-02-TC-0040, CON-Z3-UTIL-SIT-0020, CON-Z3-FS-03-TC-0040, CON-Z3-AS-03-TC-0040, CON-Z3-Tl01-TC-90, CON-Z3-PS-05-TC-0030, CON-Z3-FS-07-TC-0040, CON-Z3-FS-08-TC-350, CON-Z3-AS-02-TC-0020, CON-Z3-AS-05-TC-0040, CON-Z3-Tl01-TC-140, CON-Z3-PS-03-TC-0030, CON-Z3-FS-05-TC-0040, CON-Z3-AS-04-TC-0040, CON-Z3-FS-04-TC-0040, CON-Z3-FS-01-TC-0040 | 0.2d | 0d | RPI 2 - Thuwal (7 days Calendar) | NOT | GEN |
| GE-ML-GE-GE-GE-0160 |  | Final Mechanical Completion | milestone | 0d | 2017-12-01 | 2017-12-01 | CO-PD-PC-PC-GE-0030, CO-PD-PC-PC-GE-0040 FF, CON-Z4-LS9-TC-0060, CON-Z3-UTIL-SIT-0020, GE-ML-GE-GE-GE-0000, GE-ML-GE-GE-GE-0090, RPI-Z3-LS10-TC-0060, GE-ML-GE-GE-GE-0070, GE-ML-GE-GE-GE-0120, GE-ML-GE-GE-GE-0150 FS+30d, CO-PD-PC-PC-GE-0020, CO-PD-DM-RD-GE-0010, CO-PD-PC-PC-GE-0040, RPI-Z3-LS11-TC-0060, GE-ML-GE-GE-GE-0080, GE-ML-GE-GE-GE-0110, GE-ML-GE-GE-GE-0140 FS+30d, CO-PD-PC-PC-GE-0090, CON-Z4-UTIL-SIT-10 | 0.2d | 0d | RPI 2 - Thuwal (7 days Calendar) | NOT | GEN |
| GE-ML-GE-GE-GE-0170 |  | Complete Project Record Books and Submit As-Built Drawings & other required documents | milestone | 0d | 2017-12-01 | 2017-12-01 | GE-ML-GE-GE-GE-0160, CO-PD-DM-RB-GE-0010, CO-PD-DM-AB-GE-0010 | 30.2d |  | RPI 2 - Thuwal (7 days Calendar) | NOT | GEN |
| GE-ML-GE-GE-GE-0180 |  | Removal of All remaining Jersey Barrier Fencing (Including Lean Concrete, Construction Debris, Temp. Lighting & Cleanup | milestone | 0d | 2017-12-31 | 2017-12-31 | CO-PD-DM-JB-GE-0010, GE-ML-GE-GE-GE-0170, GE-ML-GE-GE-GE-0000 | 30d |  | RPI 2 - Thuwal (7 days Calendar) | NOT | GEN |
| GE-ML-GE-GE-GE-0190 |  | Project Completion and Demobilization | milestone | 0d | 2018-01-30 | 2018-01-30 | CO-PD-DM-AB-GE-0010, CO-PD-PC-PC-GE-0080, CO-PD-DM-PT-GE-0010, CO-PD-DM-DM-GE-0010, GE-CO-DL-GE-GE-0130 FS+490d, CO-PD-DM-RD-GE-0010, CO-PD-DM-JB-GE-0010, CO-PD-DM-DM-GE-0050, CO-PD-DM-DM-GE-0020, CO-PD-DM-DM-GE-0030, CO-PD-DM-DM-GE-0040, CON-CON-CON-CON-0020, GE-ML-GE-GE-GE-0000, GE-ML-GE-GE-GE-0180, CO-PD-DM-RB-GE-0010, CO-PD-DM-JB-GE-0010 FF | 0d |  | RPI 2 - Thuwal (7 days Calendar) | NOT | GEN |
|  | 3 | **ENGINEERING** |  |  | 2016-09-03 | 2017-02-14 |  |  |  |  |  |  |
|  | 2 | **Shop Drawings** |  |  | 2016-10-09 | 2017-02-14 |  |  |  |  |  |  |
| GE-DWG-ENG-ENG-0010 |  | Submission & Approval of Shop Drawings - Civil Works |  | 60d | 2016-10-09 | 2016-12-17 | GE-CL-DL-GE-GE-0080 FS+60d, GE-GE-GE-GE-GE-0010 | 41d | 0d |  | OK | ENG |
| GE-DWG-ENG-ENG-0020 |  | Submission & Approval of Shop Drawings - Mechanical Works |  | 60d | 2016-10-23 | 2016-12-31 | GE-DWG-ENG-ENG-0010 SS+12d | 41d | 0d |  | OK | ENG |
| GE-DWG-ENG-ENG-0030 |  | Submission & Approval of Shop Drawings - Electrical Works |  | 60d | 2016-11-06 | 2017-01-14 | GE-DWG-ENG-ENG-0020 SS+12d | 41d | 0d |  | OK | ENG |
| GE-DWG-ENG-ENG-0040 |  | Submission & Approval of Shop Drawings - Communication Works |  | 60d | 2016-11-20 | 2017-01-28 | GE-DWG-ENG-ENG-0030 SS+12d | 41d | 0d |  | OK | ENG |
| GE-DWG-ENG-ENG-0050 |  | Submission & Approval of Shop Drawings - Instrumentation Works |  | 60d | 2016-12-07 | 2017-02-14 | GE-DWG-ENG-ENG-0040 SS+15d | 70.4d | 40.2d |  | OK | ENG |

| ID | WBS | Activity | Type | Duration | Start | Finish | Predecessors | Total float | Free float | Resources | Cost | Wajid | RPI_P2 - PHASE | RPI_P2 - PROCUREMENT | RPI_P2 - BOQ ITEMS |
| --- | --- | --- | --- | --- | --- | --- | --- | --- | --- | --- | --- | --- | --- | --- | --- |
|  | 3 | **Method Statement, Mix Design & Procedures** |  |  | 2016-09-03 | 2016-10-12 |  |  |  |  |  |  |  |  |  |
| GE-MS-ENG-ENG-0010 |  | Submission & Approval of Method Statements, Mix Design & Procedures |  | 24d | 2016-09-03 | 2016-10-05 | GE-GE-GE-GE-GE-0010 FS+25d | 2.8d | 0d |  |  | OK | ENG |  |  |
| GE-MS-ENG-ENG-0020 |  | Submission & Approval of Method Statements, Hydrotest Packages |  | 15d | 2016-09-03 | 2016-09-25 | GE-MS-ENG-ENG-0010 SS | 2.8d | 0d |  |  | OK | ENG |  |  |
| GE-MS-ENG-ENG-0040 |  | Submission & Approval of Method Statements, Meterial Testing For Civil Works |  | 15d | 2016-09-05 | 2016-09-27 | GE-MS-ENG-ENG-0020 SS+2d | 32.8d | 0d |  |  | OK | ENG |  |  |
| GE-MS-ENG-ENG-0050 |  | Submission & Approval for Manifold |  | 26d | 2016-09-05 | 2016-10-10 | GE-MS-ENG-ENG-0040 SS | 32.8d | 2d |  |  | OK | ENG |  |  |
| GE-MS-ENG-ENG-0030 |  | Submission & Approval of Method Statements, MV Cable Testing |  | 15d | 2016-09-25 | 2016-10-12 | GE-MS-ENG-ENG-0020 SS+15d | 2.8d | 0d |  |  | OK | ENG |  |  |
|  | 4 | **PROCUREMENT** |  |  | 2016-08-09 | 2017-10-26 |  |  |  |  |  |  |  |  |  |
| PROC-GE-GE-GE-0010 |  | Start of Procurement | milestone | 0d | 2016-08-09 | 2016-08-09 | GE-GE-GE-GE-GE-0010 | 0.4d | 0d |  |  | OK | PROC | PROC |  |
| PROC-GE-GE-GE-0020 |  | Finish of Procurement | milestone | 0d | 2017-10-26 | 2017-10-26 | PR-MT-Z1-LC-14-0100, PR-MT-Z1-LC-11-0100, PR-Z3-GE-GE-214-0080, PR-Z3-GE-GE-213-0080, PR-Z3-GE-GE-236-0200, PR-Z3-GE-GE-215-0090, PR-Z3-CW-MS-31-0100, PR-Z3-CW-MS-34-0100, PR-Z3-CW-MS-29-0100, PR-Z3-GE-GE-233-0100, PR-Z3-GE-GE-237-0100, PR-Z3-UT-PW-125-0100, PR-Z3-UT-PW-133-0100, PR-Z3-UT-PW-142-0100, PR-Z3-UT-PW-147-0100, PR-Z3-UT-PW-150-0100, PR-Z3-CW-CS-89-0100, PR-Z3-CW-CS-92-0100, PR-Z3-GE-GE-247-0100, PR-Z3-CW-CS-82-0100, PR-Z3-CW-CS-77-0100, PR-Z3-CW-FO-68-0100, PR-Z3-CW-FO-66-0100, PR-Z3-LW-LS-96-0100, PR-Z3-LW-LS-93-0100, PR-Z3-LW-LS-101-0100, PR-Z3-EW-EW-49-0100, PR-Z3-EW-EW-56-0100, PR-Z4-CW-CW-166-0100, PR-Z4-CW-CW-172-0100, PR-Z4-CO-LV-184-0100, PR-Z4-UT-PW-199-0100, PR-Z4-UT-SS-205-0100, PR-Z4-UT-IR-208-0100, PR-Z3-CW-CS-88-0100, PR-Z3-CW-CW-25-0100, PR-MT-Z1-LC-10-0090, PR-MT-Z1-LC-01-0100, PR-Z4-CW-CW-161-0090, PR-Z4-CW-CW-159-0100, PR-Z4-CW-CW-167-0100, PR-Z3-GE-GE-227-0100, PR-Z3-GE-GE-225-0100, PR-Z3-CW-MS-35-0100, PR-Z3-UT-PW-127-0100, PR-Z3-UT-PW-130-0100, PR-Z3-UT-EL-156-0100, PR-Z3-UT-PW-135-0100, PR-Z3-UT-PW-139-0100, PR-Z3-UT-PW-145-0100, PR-Z3-UT-PW-148-0100, PR-Z3-UT-PW-149-0100, PR-Z3-UT-PW-146-0100, PR-Z3-CW-CS-91-0100, PR-Z3-GE-GE-246-0100, PR-Z3-CW-CS-78-0100, PR-Z3-CW-CS-75-0100, PR-Z3-CW-CS-70-0100, PR-Z3-LW-LS-120-0100, PR-Z3-LW-LS-106-0100, PR-Z3-LW-LS-107-0100, PR-Z3-LW-LS-113-0100, PR-Z3-LW-LS-99-0100, PR-Z3-EW-EW-57-0100, PR-Z3-EW-ME-61-0100, PR-Z3-EW-EW-42-0100, PR-Z4-CW-CW-173-0390, PR-Z4-CW-CW-174-0100, PR-Z4-CO-LV-189-0100, PR-Z4-CO-LV-185-0100, PR-Z4-CO-LV-190-0100, PR-Z4-UT-PW-198-0100, PR-Z4-UT-IR-209-0100, PR-Z3-GE-GE-232-0100, PR-MT-Z1-LC-09-0090, PR-MT-Z1-LC-03-0100, PR-Z4-CW-CW-162-0100, PR-Z3-GE-GE-212-0080, PR-Z3-CW-MS-30-0100, PR-Z3-GE-GE-223-0100, PR-Z3-GE-GE-234-0100, PR-Z3-GE-GE-221-0100, PR-Z3-GE-GE-236-0100, PR-Z3-UT-EL-153-0100, PR-Z3-UT-PW-141-0100, PR-Z3-CW-CS-82-0200, PR-Z3-LW-LS-109-0090, PR-Z3-LW-LS-94-0100, PR-Z3-EW-ME-63-0100, PR-Z3-EW-EW-38-0100, PR-Z3-EW-EW-53-0100, PR-Z3-EW-EW-46-0100, PR-Z3-EW-EW-47-0100, PR-Z3-EW-EW-48-0100, PR-Z3-EW-EW-52-0100, PR-Z3-CW-RW-17-0100, PR-Z4-CW-CW-164-0100, PR-Z4-CW-CW-173-0290, PR-Z4-CW-CW-169-0100, PR-Z4-UT-PW-192-0100, PR-Z4-UT-IR-210-0100, PR-Z3-CW-RW-18-0100, PR-Z3-CW-CW-24-0100, PR-MT-Z1-LC-04-0100, PR-Z4-CW-CW-157-0100, PR-Z4-CW-CW-165-0100, PR-Z3-GE-GE-238-0100, PR-Z3-GE-GE-241-0100, PR-Z3-GE-GE-242-0100, PR-Z3-UT-PW-124-0100, PR-Z3-UT-EL-154-0100, PR-Z3-UT-PW-136-0100, PR-Z3-UT-PW-144-0100, PR-Z3-UT-PW-143-0100, PR-Z3-CW-CS-71-0100, PR-Z3-CW-CS-85-0100, PR-Z3-CW-CS-74-0100, PR-Z3-CW-CS-72-0100, PR-Z3-CW-CS-73-0090, PR-Z3-CW-FO-69-0100, PR-Z3-LW-LS-119-0100, PR-Z3-LW-LS-114-0200, PR-Z3-LW-LS-115-0100, PR-Z3-LW-LS-114-0100, PR-Z3-LW-LS-95-0100, PR-Z3-EW-EW-58-0100, PR-Z3-EW-EW-39-0090, PR-Z3-EW-EW-51-0100, PR-Z3-EW-EW-44-0100, PR-Z4-CW-CW-171-0100, PR-Z4-CW-CW-173-0490, PR-Z4-EW-EL-179-190, PR-Z4-CO-LV-188-0100, PR-Z4-CO-LV-186-0100, PR-Z4-CO-LV-184-190, PR-Z3-CW-RW-19-0100, PR-Z3-CW-RW-16-0100, PR-Z3-CW-CW-23-0100, PR-Z3-GE-GE-228-0100, PR-Z4-CW-CW-163-0100, PR-Z3-GE-GE-211-0080, PR-Z3-GE-GE-229-0100, PR-Z3-GE-GE-220-0100, PR-Z3-GE-GE-239-0100, PR-Z3-UT-PW-121-0100, PR-Z3-UT-EL-155-0100, PR-Z3-UT-PW-132-0100, PR-Z3-UT-PW-151-0100, PR-Z3-CW-CS-86-0100, PR-Z3-CW-CS-87-0100, PR-Z3-LW-LS-108-180, PR-Z3-LW-LS-117-0100, PR-Z3-LW-LS-103-0100, PR-Z3-GE-GE-249-0100, PR-Z3-EW-ME-62-0100, PR-Z3-EW-EW-37-0100, PR-Z3-EW-EW-41-0090, PR-Z3-EW-EW-43-0100, PR-Z4-CW-CW-173-0190, PR-Z4-EW-EL-180-0100, PR-Z4-CO-LV-182-0100, PR-Z4-CO-LV-183-0100, PR-Z4-UT-SE-204-0100, PR-Z4-UT-PW-200-0100, PR-Z4-UT-PW-193-0100, PR-Z3-CW-CW-20-0090, PR-Z4-CW-CW-160-0100, PR-Z3-GE-GE-217-0100, PR-Z3-GE-GE-216-0100, PR-Z3-GE-GE-224-0100, PR-Z3-CW-MS-28-0100, PR-Z3-GE-GE-235-0100, PR-Z3-GE-GE-243-0100, PR-Z3-UT-PW-126-0100, PR-Z3-UT-PW-131-0100, PR-Z3-CW-CS-90-0100, PR-Z3-GE-GE-245-0100, PR-Z3-LW-LS-118-0100, PR-Z3-LW-LS-98-0100, PR-Z3-EW-ME-64-0100, PR-Z3-EW-EW-36-0100, PR-Z3-EW-EW-54-0100, PR-Z4-CW-CW-168-0100, PR-Z4-CW-CW-173-0100, PR-Z4-EW-EL-179-0100, PR-Z4-CO-LV-181-0100, PR-Z4-UT-SE-202-0100, PR-Z4-UT-PW-194-0100, PR-Z4-UT-PW-195-0100, PR-Z4-UT-IR-206-0100, PR-Z3-CW-CW-21-0090, PR-Z3-CW-MS-32-0100, PR-MT-Z1-LC-07-0100, PR-MT-Z1-LC-13-0090, PR-MT-Z1-LC-02-0100, PR-MT-Z1-LC-12-0100, PR-LW-Z2-GE-15-0100, PR-Z3-GE-GE-226-0100, PR-Z3-GE-GE-240-0100, PR-Z3-UT-PW-129-0100, PR-Z3-UT-EL-152-0090, PR-Z3-UT-PW-138-0100, PR-Z3-CW-CS-76-0100, PR-Z3-CW-CS-79-0100, PR-Z3-CW-CS-80-0100, PR-Z3-LW-LS-109-180, PR-Z3-LW-LS-105-0100, PR-Z3-LW-LS-114-0010, PR-Z3-LW-LS-102-0100, PR-Z3-LW-LS-97-0100, PR-Z3-EW-ME-65-0100, PR-Z3-GE-GE-250-0100, PR-Z3-EW-EW-45-0100, PR-Z4-CW-CW-170-0100, PR-Z4-CO-LV-187-0100, PR-Z4-UT-SE-203-0100, PR-Z4-UT-IR-207-0100, PR-Z3-CW-CW-26-0100, PR-Z3-CW-CW-22-0090, PR-Z3-CW-MS-27-0100, PR-Z3-GE-GE-231-0100, PR-MT-Z1-LC-06-0100, PR-MT-Z1-LC-05-0100, PR-MT-Z1-LC-08-0090, PR-Z4-CW-CW-158-0100, PR-Z3-GE-GE-218-0100, PR-Z3-GE-GE-222-0100, PR-Z3-GE-GE-244-0100, PR-Z3-UT-PW-122-0100, PR-Z3-UT-PW-128-0100, PR-Z3-UT-PW-123-0100, PR-Z3-UT-PW-137-0100, PR-Z3-UT-PW-134-0100, PR-Z3-UT-PW-140-0100, PR-Z3-CW-CS-83-0100, PR-Z3-CW-CS-81-0100, PR-Z3-CW-CS-84-0100, PR-Z3-CW-FO-67-0100, PR-Z3-LW-LS-104-0100, PR-Z3-LW-LS-111-0100, PR-Z3-LW-LS-116-0100, PR-Z3-LW-LS-112-0100, PR-Z3-LW-LS-100-0100, PR-Z3-EW-ME-59-0100, PR-Z3-EW-ME-60-0100, PR-Z3-EW-EW-40-0090, PR-Z3-EW-EW-50-0100, PR-Z3-EW-EW-55-0100, PR-Z4-UT-SE-201-0100, PR-Z4-UT-PW-196-0100, PR-Z4-UT-PW-197-0100, PR-Z4-UT-PW-191-0100, PR-Z3-CW-MS-33-0100, PR-Z3-GE-GE-230-0100 | 82.2d |  |  |  | NOT | PROC | PROC |  |
|  | 1 | **MATERIAL FOR ZONE - 1 & 2** |  |  | 2016-08-17 | 2017-08-27 |  |  |  |  |  |  |  |  |  |
|  | 1 | **COMMUNICATION WORKS - (MATERIAL)** |  |  | 2016-08-17 | 2017-05-17 |  |  |  |  |  |  |  |  |  |
|  | 1 | **Fiber Optics and Copper Cable System** |  |  | 2016-09-18 | 2017-04-27 |  |  |  |  |  |  |  |  |  |
|  | 1 | **FOC - Copper Cables** |  |  | 2016-09-18 | 2017-04-23 |  |  |  |  |  |  |  |  |  |
| PR-MT-Z1-LC-01-0010 |  | RFQ - Copper Cables |  | 7d | 2016-09-18 | 2016-09-26 | PROC-GE-GE-GE-0010 FS+30d | 68.8d | 0d |  |  | OK | PROC | PROC | 1.2.1.10 |
| PR-MT-Z1-LC-01-0020 |  | Material Submittal - Copper Cables |  | 6d | 2016-09-26 | 2016-10-03 | PR-MT-Z1-LC-01-0010 | 68.8d | 0d |  |  | OK | PROC | PROC | 1.2.1.10 |
| PR-MT-Z1-LC-01-0030 |  | Material Approval - Copper Cables |  | 14d | 2016-10-03 | 2016-10-19 | PR-MT-Z1-LC-01-0020 | 68.8d | 0d |  |  | OK | PROC | PROC | 1.2.1.10 |
| PR-MT-Z1-LC-01-0040 |  | Technical Evaluation - Copper Cables |  | 10d | 2016-10-19 | 2016-10-31 | PR-MT-Z1-LC-01-0030 | 68.8d | 0d |  |  | OK | PROC | PROC | 1.2.1.10 |
| PR-MT-Z1-LC-01-0050 |  | PO - Copper Cables |  | 14d | 2016-10-31 | 2016-11-16 | PR-MT-Z1-LC-01-0040 | 68.8d | 0d |  |  | OK | PROC | PROC | 1.2.1.10 |
| PR-MT-Z1-LC-01-0060 |  | NMR 601 - Copper Cables |  | 6d | 2016-11-16 | 2016-11-23 | PR-MT-Z1-LC-01-0050 | 68.8d | 0d |  |  | OK | PROC | PROC | 1.2.1.10 |
| PR-MT-Z1-LC-01-0070 |  | NMR 602 - Copper Cables |  | 6d | 2016-11-23 | 2016-11-30 | PR-MT-Z1-LC-01-0060 | 68.8d | 0d |  |  | OK | PROC | PROC | 1.2.1.10 |
| PR-MT-Z1-LC-01-0080 |  | Start of Material Delivery - Copper Cables | milestone | 0d | 2017-03-25 | 2017-03-25 | PR-MT-Z1-LC-01-0070 FS+98d | 68.8d | 0d |  |  | OK | PROC | PROC | 1.2.1.10 |
| PR-MT-Z1-LC-01-0090 |  | Complete Material Delivery - Copper Cables |  | 15d | 2017-03-25 | 2017-04-11 | PR-MT-Z1-LC-01-0080 | 68.8d | 0d | FOC - Copper Cables [1622 Lm] | 31,634.12 | OK | PROC | PROC | 1.2.1.10 |
| PR-MT-Z1-LC-01-0100 |  | NMR 603 - Copper Cables |  | 10d | 2017-04-11 | 2017-04-23 | PR-MT-Z1-LC-01-0090 | 233.8d | 151.6d |  |  | OK | PROC | PROC | 1.2.1.10 |
|  | 2 | **Copper Splices** |  |  | 2016-09-18 | 2017-04-27 |  |  |  |  |  |  |  |  |  |
| PR-MT-Z1-LC-02-0010 |  | RFQ - Copper Splices |  | 7d | 2016-09-18 | 2016-09-26 | PROC-GE-GE-GE-0010 FS+20d, PR-MT-Z1-LC-01-0010 SS | 92.8d | 0d |  |  | OK | PROC | PROC | 1.2.1.10 |
| PR-MT-Z1-LC-02-0020 |  | Material Submittal - Copper Splices |  | 10d | 2016-09-26 | 2016-10-08 | PR-MT-Z1-LC-02-0010 | 92.8d | 0d |  |  | OK | PROC | PROC | 1.2.1.10 |
| PR-MT-Z1-LC-02-0030 |  | Material Approval - Copper Splices |  | 14d | 2016-10-08 | 2016-10-24 | PR-MT-Z1-LC-02-0020 | 92.8d | 0d |  |  | OK | PROC | PROC | 1.2.1.10 |
| PR-MT-Z1-LC-02-0040 |  | Technical Evaluation - Copper Splices |  | 10d | 2016-10-24 | 2016-11-05 | PR-MT-Z1-LC-02-0030 | 92.8d | 0d |  |  | OK | PROC | PROC | 1.2.1.10 |
| PR-MT-Z1-LC-02-0050 |  | PO - Copper Splices |  | 14d | 2016-11-05 | 2016-11-21 | PR-MT-Z1-LC-02-0040 | 92.8d | 0d |  |  | OK | PROC | PROC | 1.2.1.10 |
| PR-MT-Z1-LC-02-0060 |  | NMR 601 - Copper Splices |  | 6d | 2016-11-21 | 2016-11-28 | PR-MT-Z1-LC-02-0050 | 92.8d | 0d |  |  | OK | PROC | PROC | 1.2.1.10 |
| PR-MT-Z1-LC-02-0070 |  | NMR 602 - Copper Splices |  | 6d | 2016-11-28 | 2016-12-05 | PR-MT-Z1-LC-02-0060 | 92.8d | 0d |  |  | OK | PROC | PROC | 1.2.1.10 |
| PR-MT-Z1-LC-02-0080 |  | Start of Material Delivery - Copper Splices | milestone | 0d | 2017-03-29 | 2017-03-29 | PR-MT-Z1-LC-02-0070 FS+98d | 92.8d | 0d |  |  | OK | PROC | PROC | 1.2.1.10 |
| PR-MT-Z1-LC-02-0090 |  | Complete Material Delivery - Copper Splices |  | 15d | 2017-03-29 | 2017-04-16 | PR-MT-Z1-LC-02-0080 | 92.8d | 0d | Copper Splices [14 ea] | 250,127.97 | OK | PROC | PROC | 1.2.1.10 |
| PR-MT-Z1-LC-02-0100 |  | NMR 603 - Copper Splices |  | 10d | 2017-04-16 | 2017-04-27 | PR-MT-Z1-LC-02-0090 | 229.8d | 147.6d |  |  | OK | PROC | PROC | 1.2.1.10 |

Notes:
- PR-MT-Z1-LC-01-0090: Expenses: (New Expense Item) 31634.1
- PR-MT-Z1-LC-02-0090: Expenses: (New Expense Item) 250128

| ID | WBS | Activity | Type | Duration | Start | Finish | Predecessors | Total float | Free float | Resources | Cost | Wajid | RPI_P2 - BOQ ITEMS | RPI_P2 - PROCUREMENT | RPI_P2 - PHASE |
| --- | --- | --- | --- | --- | --- | --- | --- | --- | --- | --- | --- | --- | --- | --- | --- |
|  | 2 | **Communication and Security System** |  |  | 2016-08-17 | 2017-05-17 |  |  |  |  |  |  |  |  |  |
|  | 1 | **Co-Axial Cables** |  |  | 2016-10-08 | 2017-04-13 |  |  |  |  |  |  |  |  |  |
| PR-MT-Z1-LC-03-0010 |  | RFQ - Co-Axial Cables |  | 7d | 2016-10-08 | 2016-10-16 | PROC-GE-GE-GE-0010 FS+47d | 56.8d | 0d |  |  | OK | 1.2.1.20 | PROC | PROC |
| PR-MT-Z1-LC-03-0020 |  | Material Submittal - Co-Axial Cables |  | 10d | 2016-10-16 | 2016-10-27 | PR-MT-Z1-LC-03-0010 | 56.8d | 0d |  |  | OK | 1.2.1.20 | PROC | PROC |
| PR-MT-Z1-LC-03-0030 |  | Material Approval - Co-Axial Cables |  | 14d | 2016-10-27 | 2016-11-13 | PR-MT-Z1-LC-03-0020 | 56.8d | 0d |  |  | OK | 1.2.1.20 | PROC | PROC |
| PR-MT-Z1-LC-03-0040 |  | Technical Evaluation - Co-Axial Cables |  | 10d | 2016-11-13 | 2016-11-24 | PR-MT-Z1-LC-03-0030 | 56.8d | 0d |  |  | OK | 1.2.1.20 | PROC | PROC |
| PR-MT-Z1-LC-03-0050 |  | PO - Co-Axial Cables |  | 14d | 2016-11-24 | 2016-12-11 | PR-MT-Z1-LC-03-0040 | 56.8d | 0d |  |  | OK | 1.2.1.20 | PROC | PROC |
| PR-MT-Z1-LC-03-0060 |  | NMR 601 - Co-Axial Cables |  | 6d | 2016-12-11 | 2016-12-18 | PR-MT-Z1-LC-03-0050 | 241.8d | 0d |  |  | OK | 1.2.1.20 | PROC | PROC |
| PR-MT-Z1-LC-03-0070 |  | NMR 602 - Co-Axial Cables |  | 6d | 2016-12-18 | 2016-12-25 | PR-MT-Z1-LC-03-0060 | 241.8d | 0d |  |  | OK | 1.2.1.20 | PROC | PROC |
| PR-MT-Z1-LC-03-0080 |  | Start of Material Delivery - Co-Axial Cables | milestone | 0d | 2017-03-15 | 2017-03-15 | PR-MT-Z1-LC-03-0070 FS+69d | 241.8d | 0d |  |  | OK | 1.2.1.20 | PROC | PROC |
| PR-MT-Z1-LC-03-0090 |  | Complete Material Delivery - Co-Axial Cables |  | 15d | 2017-03-15 | 2017-04-02 | PR-MT-Z1-LC-03-0080 | 241.8d | 0d | Co-Axial Cables [310 Lm] | 11,388.43 | OK | 1.2.1.20 | PROC | PROC |
| PR-MT-Z1-LC-03-0100 |  | NMR 603 - Co-Axial Cables |  | 10d | 2017-04-02 | 2017-04-13 | PR-MT-Z1-LC-03-0090 | 241.8d | 159.6d |  |  | OK | 1.2.1.20 | PROC | PROC |
|  | 2 | **Copper Control Cables** |  |  | 2016-10-08 | 2017-04-13 |  |  |  |  |  |  |  |  |  |
| PR-MT-Z1-LC-04-0010 |  | RFQ - Copper Control Cables |  | 7d | 2016-10-08 | 2016-10-16 | PROC-GE-GE-GE-0010 FS+47.2d | 56.6d | 0d |  |  | OK | 1.2.1.20 | PROC | PROC |
| PR-MT-Z1-LC-04-0020 |  | Material Submittal - Copper Control Cables |  | 10d | 2016-10-16 | 2016-10-27 | PR-MT-Z1-LC-04-0010 | 56.6d | 0d |  |  | OK | 1.2.1.20 | PROC | PROC |
| PR-MT-Z1-LC-04-0030 |  | Material Approval - Copper Control Cables |  | 14d | 2016-10-27 | 2016-11-13 | PR-MT-Z1-LC-04-0020 | 56.6d | 0d |  |  | OK | 1.2.1.20 | PROC | PROC |
| PR-MT-Z1-LC-04-0040 |  | Technical Evaluation - Copper Control Cables |  | 10d | 2016-11-13 | 2016-11-24 | PR-MT-Z1-LC-04-0030 | 56.6d | 0d |  |  | OK | 1.2.1.20 | PROC | PROC |
| PR-MT-Z1-LC-04-0050 |  | PO - Copper Control Cables |  | 14d | 2016-11-24 | 2016-12-11 | PR-MT-Z1-LC-04-0040 | 56.6d | 0d |  |  | OK | 1.2.1.20 | PROC | PROC |
| PR-MT-Z1-LC-04-0060 |  | NMR 601 - Copper Control Cables |  | 6d | 2016-12-11 | 2016-12-18 | PR-MT-Z1-LC-04-0050 | 241.6d | 0d |  |  | OK | 1.2.1.20 | PROC | PROC |
| PR-MT-Z1-LC-04-0070 |  | NMR 602 - Copper Control Cables |  | 6d | 2016-12-18 | 2016-12-25 | PR-MT-Z1-LC-04-0060 | 241.6d | 0d |  |  | OK | 1.2.1.20 | PROC | PROC |
| PR-MT-Z1-LC-04-0080 |  | Start of Material Delivery - Copper Control Cables | milestone | 0d | 2017-03-15 | 2017-03-15 | PR-MT-Z1-LC-04-0070 FS+69d | 241.6d | 0d |  |  | OK | 1.2.1.20 | PROC | PROC |
| PR-MT-Z1-LC-04-0090 |  | Complete Material Delivery - Copper Control Cables |  | 15d | 2017-03-15 | 2017-04-02 | PR-MT-Z1-LC-04-0080 | 241.6d | 0d | FOC - Copper Cables [40 Lm] | 1,175.58 | OK | 1.2.1.20 | PROC | PROC |
| PR-MT-Z1-LC-04-0100 |  | NMR 603 - Copper Control Cables |  | 10d | 2017-04-02 | 2017-04-13 | PR-MT-Z1-LC-04-0090 | 241.6d | 159.4d |  |  | OK | 1.2.1.20 | PROC | PROC |
|  | 3 | **Splicing FOC** |  |  | 2016-10-08 | 2017-05-17 |  |  |  |  |  |  |  |  |  |
| PR-MT-Z1-LC-05-0010 |  | RFQ - Splicing FOC |  | 7d | 2016-10-08 | 2016-10-16 | PR-MT-Z1-LC-04-0010 SS, PROC-GE-GE-GE-0010 FS+20d | 56.6d | 0d |  |  | OK | 1.2.1.20 | PROC | PROC |
| PR-MT-Z1-LC-05-0020 |  | Material Submittal - Splicing FOC |  | 10d | 2016-10-16 | 2016-10-27 | PR-MT-Z1-LC-05-0010 | 56.6d | 0d |  |  | OK | 1.2.1.20 | PROC | PROC |
| PR-MT-Z1-LC-05-0030 |  | Material Approval - Splicing FOC |  | 14d | 2016-10-27 | 2016-11-13 | PR-MT-Z1-LC-05-0020 | 56.6d | 0d |  |  | OK | 1.2.1.20 | PROC | PROC |
| PR-MT-Z1-LC-05-0040 |  | Technical Evaluation - Splicing FOC |  | 10d | 2016-11-13 | 2016-11-24 | PR-MT-Z1-LC-05-0030 | 56.6d | 0d |  |  | OK | 1.2.1.20 | PROC | PROC |
| PR-MT-Z1-LC-05-0050 |  | PO - Splicing FOC |  | 14d | 2016-11-24 | 2016-12-11 | PR-MT-Z1-LC-05-0040 | 56.6d | 0d |  |  | OK | 1.2.1.20 | PROC | PROC |
| PR-MT-Z1-LC-05-0060 |  | NMR 601 - Splicing FOC |  | 6d | 2016-12-11 | 2016-12-18 | PR-MT-Z1-LC-05-0050 | 212.6d | 0d |  |  | OK | 1.2.1.20 | PROC | PROC |
| PR-MT-Z1-LC-05-0070 |  | NMR 602 - Splicing FOC |  | 6d | 2016-12-18 | 2016-12-25 | PR-MT-Z1-LC-05-0060 | 212.6d | 0d |  |  | OK | 1.2.1.20 | PROC | PROC |
| PR-MT-Z1-LC-05-0080 |  | Start of Material Delivery - Splicing FOC | milestone | 0d | 2017-04-18 | 2017-04-18 | PR-MT-Z1-LC-05-0070 FS+98d | 212.6d | 0d |  |  | OK | 1.2.1.20 | PROC | PROC |
| PR-MT-Z1-LC-05-0090 |  | Complete Material Delivery - Splicing FOC |  | 15d | 2017-04-18 | 2017-05-06 | PR-MT-Z1-LC-05-0080 | 212.6d | 0d | Splicing FOC [10 ea] | 86,699.02 | OK | 1.2.1.20 | PROC | PROC |
| PR-MT-Z1-LC-05-0100 |  | NMR 603 - Splicing FOC |  | 10d | 2017-05-06 | 2017-05-17 | PR-MT-Z1-LC-05-0090 | 212.6d | 130.4d |  |  | OK | 1.2.1.20 | PROC | PROC |

Notes:
- PR-MT-Z1-LC-03-0090: Expenses: (New Expense Item) 11388.4
- PR-MT-Z1-LC-04-0090: Expenses: (New Expense Item) 1175.58
- PR-MT-Z1-LC-05-0090: Expenses: (New Expense Item) 86699

| ID | WBS | Activity | Type | Duration | Start | Finish | Predecessors | Total float | Free float | Resources | Cost | Wajid | RPI_P2 - BOQ ITEMS | RPI_P2 - PROCUREMENT | RPI_P2 - PHASE |
| --- | --- | --- | --- | --- | --- | --- | --- | --- | --- | --- | --- | --- | --- | --- | --- |
|  | 4 | **Code Blue Pedestal** |  |  | 2016-10-09 | 2017-05-13 |  |  |  |  |  |  |  |  |  |
| PR-MT-Z1-LC-06-0010 |  | RFQ - Code Blue Pedestal |  | 7d | 2016-10-09 | 2016-10-17 | PROC-GE-GE-GE-0010 FS+48d | 55.8d | 0d |  |  | OK | 1.2.1.20 | PROC | PROC |
| PR-MT-Z1-LC-06-0020 |  | Material Submittal - Code Blue Pedestal |  | 10d | 2016-10-17 | 2016-10-29 | PR-MT-Z1-LC-06-0010 | 55.8d | 0d |  |  | OK | 1.2.1.20 | PROC | PROC |
| PR-MT-Z1-LC-06-0030 |  | Material Approval - Code Blue Pedestal |  | 14d | 2016-10-29 | 2016-11-14 | PR-MT-Z1-LC-06-0020 | 55.8d | 0d |  |  | OK | 1.2.1.20 | PROC | PROC |
| PR-MT-Z1-LC-06-0040 |  | Technical Evaluation - Code Blue Pedestal |  | 10d | 2016-11-14 | 2016-11-26 | PR-MT-Z1-LC-06-0030 | 55.8d | 0d |  |  | OK | 1.2.1.20 | PROC | PROC |
| PR-MT-Z1-LC-06-0050 |  | PO - Code Blue Pedestal |  | 14d | 2016-11-26 | 2016-12-12 | PR-MT-Z1-LC-06-0040 | 55.8d | 0d |  |  | OK | 1.2.1.20 | PROC | PROC |
| PR-MT-Z1-LC-06-0060 |  | NMR 601 - Code Blue Pedestal |  | 6d | 2016-12-12 | 2016-12-19 | PR-MT-Z1-LC-06-0050 | 125.8d | 0d |  |  | OK | 1.2.1.20 | PROC | PROC |
| PR-MT-Z1-LC-06-0070 |  | NMR 602 - Code Blue Pedestal |  | 6d | 2016-12-19 | 2016-12-26 | PR-MT-Z1-LC-06-0060 | 125.8d | 0d |  |  | OK | 1.2.1.20 | PROC | PROC |
| PR-MT-Z1-LC-06-0080 |  | Start of Material Delivery - Code Blue Pedestal | milestone | 0d | 2017-04-13 | 2017-04-13 | PR-MT-Z1-LC-06-0070 FS+93d | 125.8d | 0d |  |  | OK | 1.2.1.20 | PROC | PROC |
| PR-MT-Z1-LC-06-0090 |  | Complete Material Delivery - Code Blue Pedestal |  | 15d | 2017-04-13 | 2017-05-01 | PR-MT-Z1-LC-06-0080 | 125.8d | 0d | Code Blue Pedestal [8 ea] | 539,003.37 | OK | 1.2.1.20 | PROC | PROC |
| PR-MT-Z1-LC-06-0100 |  | NMR 603 - Code Blue Pedestal |  | 10d | 2017-05-01 | 2017-05-13 | PR-MT-Z1-LC-06-0090 | 216.8d | 134.6d |  |  | OK | 1.2.1.20 | PROC | PROC |
|  | 5 | **Code Blue LV Cables** |  |  | 2016-10-09 | 2017-05-13 |  |  |  |  |  |  |  |  |  |
| PR-MT-Z1-LC-07-0010 |  | RFQ - Code Blue LV Cables |  | 7d | 2016-10-09 | 2016-10-17 | PROC-GE-GE-GE-0010 FS+48d | 55.8d | 0d |  |  | OK | 1.2.1.20 | PROC | PROC |
| PR-MT-Z1-LC-07-0020 |  | Material Submittal - Code Blue LV Cables |  | 10d | 2016-10-17 | 2016-10-29 | PR-MT-Z1-LC-07-0010 | 55.8d | 0d |  |  | OK | 1.2.1.20 | PROC | PROC |
| PR-MT-Z1-LC-07-0030 |  | Material Approval - Code Blue LV Cables |  | 14d | 2016-10-29 | 2016-11-14 | PR-MT-Z1-LC-07-0020 | 55.8d | 0d |  |  | OK | 1.2.1.20 | PROC | PROC |
| PR-MT-Z1-LC-07-0040 |  | Technical Evaluation - Code Blue LV Cables |  | 10d | 2016-11-14 | 2016-11-26 | PR-MT-Z1-LC-07-0030 | 55.8d | 0d |  |  | OK | 1.2.1.20 | PROC | PROC |
| PR-MT-Z1-LC-07-0050 |  | PO - Code Blue LV Cables |  | 14d | 2016-11-26 | 2016-12-12 | PR-MT-Z1-LC-07-0040 | 55.8d | 0d |  |  | OK | 1.2.1.20 | PROC | PROC |
| PR-MT-Z1-LC-07-0060 |  | NMR 601 - Code Blue LV Cables |  | 6d | 2016-12-12 | 2016-12-19 | PR-MT-Z1-LC-07-0050 | 88.8d | 0d |  |  | OK | 1.2.1.20 | PROC | PROC |
| PR-MT-Z1-LC-07-0070 |  | NMR 602 - Code Blue LV Cables |  | 6d | 2016-12-19 | 2016-12-26 | PR-MT-Z1-LC-07-0060 | 88.8d | 0d |  |  | OK | 1.2.1.20 | PROC | PROC |
| PR-MT-Z1-LC-07-0080 |  | Start of Material Delivery - Code Blue LV Cables | milestone | 0d | 2017-04-13 | 2017-04-13 | PR-MT-Z1-LC-07-0070 FS+93d | 88.8d | 0d |  |  | OK | 1.2.1.20 | PROC | PROC |
| PR-MT-Z1-LC-07-0090 |  | Complete Material Delivery - Code Blue LV Cables |  | 15d | 2017-04-13 | 2017-05-01 | PR-MT-Z1-LC-07-0080 | 88.8d | 0d | Code Blue LV Cables [2033 Lm] | 40,569.47 | OK | 1.2.1.20 | PROC | PROC |
| PR-MT-Z1-LC-07-0100 |  | NMR 603 - Code Blue LV Cables |  | 10d | 2017-05-01 | 2017-05-13 | PR-MT-Z1-LC-07-0090 | 216.8d | 134.6d |  |  | OK | 1.2.1.20 | PROC | PROC |
|  | 6 | **Sand for Backfilling** |  |  | 2016-08-17 | 2017-02-21 |  |  |  |  |  |  |  |  |  |
| PR-MT-Z1-LC-08-0010 |  | RFQ - Sand for Backfilling |  | 7d | 2016-08-17 | 2016-08-24 | PROC-GE-GE-GE-0010 FS+7d | 96.8d | 0d |  |  | OK | 1.2.1.20 | PROC | PROC |
| PR-MT-Z1-LC-08-0020 |  | Material Submittal - Sand for Backfilling |  | 10d | 2016-08-25 | 2016-09-05 | PR-MT-Z1-LC-08-0010 | 96.8d | 0d |  |  | OK | 1.2.1.20 | PROC | PROC |
| PR-MT-Z1-LC-08-0030 |  | Material Approval - Sand for Backfilling |  | 14d | 2016-09-06 | 2016-09-27 | PR-MT-Z1-LC-08-0020 | 96.8d | 0d |  |  | OK | 1.2.1.20 | PROC | PROC |
| PR-MT-Z1-LC-08-0040 |  | Technical Evaluation - Sand for Backfilling |  | 10d | 2016-09-27 | 2016-10-09 | PR-MT-Z1-LC-08-0030 | 96.8d | 0d |  |  | OK | 1.2.1.20 | PROC | PROC |
| PR-MT-Z1-LC-08-0050 |  | PO - Sand for Backfilling |  | 14d | 2016-10-09 | 2016-10-25 | PR-MT-Z1-LC-08-0040 | 96.8d | 0d |  |  | OK | 1.2.1.20 | PROC | PROC |
| PR-MT-Z1-LC-08-0060 |  | NMR 601 - Sand for Backfilling |  | 6d | 2016-10-25 | 2016-11-01 | PR-MT-Z1-LC-08-0050 | 173.8d | 0d |  |  | OK | 1.2.1.20 | PROC | PROC |
| PR-MT-Z1-LC-08-0070 |  | NMR 602 - Sand for Backfilling |  | 6d | 2016-11-01 | 2016-11-08 | PR-MT-Z1-LC-08-0060 | 173.8d | 0d |  |  | OK | 1.2.1.20 | PROC | PROC |
| PR-MT-Z1-LC-08-0080 |  | Start of Material Delivery - Sand for Backfilling | milestone | 0d | 2017-01-17 | 2017-01-17 | PR-MT-Z1-LC-08-0070 FS+60d | 173.8d | 0d |  |  | OK | 1.2.1.20 | PROC | PROC |
| PR-MT-Z1-LC-08-0090 |  | Complete Material Delivery - Sand for Backfilling |  | 30d | 2017-01-17 | 2017-02-21 | PR-MT-Z1-LC-08-0080 | 173.8d | 166d | Sand for Backfilling [643.25 Cum] | 63,632.94 | OK | 1.2.1.20 | PROC | PROC |

Notes:
- PR-MT-Z1-LC-06-0090: Expenses: (New Expense Item) 539003
- PR-MT-Z1-LC-07-0090: Expenses: (New Expense Item) 40569.5
- PR-MT-Z1-LC-08-0090: Expenses: (New Expense Item) 63632.9

| ID | WBS | Activity | Type | Duration | Start | Finish | Predecessors | Total float | Free float | Resources | Cost | Wajid | RPI_P2 - BOQ ITEMS | RPI_P2 - PROCUREMENT | RPI_P2 - PHASE |
| --- | --- | --- | --- | --- | --- | --- | --- | --- | --- | --- | --- | --- | --- | --- | --- |
|  | 7 | **Warning Tapes** |  |  | 2016-08-28 | 2017-01-11 |  |  |  |  |  |  |  |  |  |
| PR-MT-Z1-LC-09-0010 |  | RFQ - Warning Tapes |  | 7d | 2016-08-28 | 2016-09-04 | PROC-GE-GE-GE-0010 FS+16d | 87.8d | 0d |  |  | OK | 1.2.1.20 | PROC | PROC |
| PR-MT-Z1-LC-09-0020 |  | Material Submittal - Warning Tapes |  | 10d | 2016-09-05 | 2016-09-21 | PR-MT-Z1-LC-09-0010 | 87.8d | 0d |  |  | OK | 1.2.1.20 | PROC | PROC |
| PR-MT-Z1-LC-09-0030 |  | Material Approval - Warning Tapes |  | 14d | 2016-09-21 | 2016-10-08 | PR-MT-Z1-LC-09-0020 | 87.8d | 0d |  |  | OK | 1.2.1.20 | PROC | PROC |
| PR-MT-Z1-LC-09-0040 |  | Technical Evaluation - Warning Tapes |  | 10d | 2016-10-08 | 2016-10-19 | PR-MT-Z1-LC-09-0030 | 87.8d | 0d |  |  | OK | 1.2.1.20 | PROC | PROC |
| PR-MT-Z1-LC-09-0050 |  | PO - Warning Tapes |  | 14d | 2016-10-19 | 2016-11-05 | PR-MT-Z1-LC-09-0040 | 87.8d | 0d |  |  | OK | 1.2.1.20 | PROC | PROC |
| PR-MT-Z1-LC-09-0060 |  | NMR 601 - Warning Tapes |  | 6d | 2016-11-05 | 2016-11-12 | PR-MT-Z1-LC-09-0050 | 216.8d | 0d |  |  | OK | 1.2.1.20 | PROC | PROC |
| PR-MT-Z1-LC-09-0070 |  | NMR 602 - Warning Tapes |  | 6d | 2016-11-12 | 2016-11-19 | PR-MT-Z1-LC-09-0060 | 216.8d | 0d |  |  | OK | 1.2.1.20 | PROC | PROC |
| PR-MT-Z1-LC-09-0080 |  | Start of Material Delivery - Warning Tapes | milestone | 0d | 2016-12-07 | 2016-12-07 | PR-MT-Z1-LC-09-0070 FS+16d | 216.8d | 0d |  |  | OK | 1.2.1.20 | PROC | PROC |
| PR-MT-Z1-LC-09-0090 |  | Complete Material Delivery - Warning Tapes |  | 30d | 2016-12-07 | 2017-01-11 | PR-MT-Z1-LC-09-0080 | 216.8d | 209d | Warning Tapes [8170 Lm] | 30,014.02 | OK | 1.2.1.20 | PROC | PROC |
|  | 8 | **Red Tiles** |  |  | 2016-09-01 | 2017-02-19 |  |  |  |  |  |  |  |  |  |
| PR-MT-Z1-LC-10-0010 |  | RFQ - Red Tiles |  | 7d | 2016-09-01 | 2016-09-08 | PROC-GE-GE-GE-0010 FS+20d | 83.8d | 0d |  |  | OK | 1.2.1.20 | PROC | PROC |
| PR-MT-Z1-LC-10-0020 |  | Material Submittal - Red Tiles |  | 10d | 2016-09-10 | 2016-09-26 | PR-MT-Z1-LC-10-0010 | 83.8d | 0d |  |  | OK | 1.2.1.20 | PROC | PROC |
| PR-MT-Z1-LC-10-0030 |  | Material Approval - Red Tiles |  | 14d | 2016-09-26 | 2016-10-12 | PR-MT-Z1-LC-10-0020 | 83.8d | 0d |  |  | OK | 1.2.1.20 | PROC | PROC |
| PR-MT-Z1-LC-10-0040 |  | Technical Evaluation - Red Tiles |  | 10d | 2016-10-12 | 2016-10-24 | PR-MT-Z1-LC-10-0030 | 83.8d | 0d |  |  | OK | 1.2.1.20 | PROC | PROC |
| PR-MT-Z1-LC-10-0050 |  | PO - Red Tiles |  | 14d | 2016-10-24 | 2016-11-09 | PR-MT-Z1-LC-10-0040 | 83.8d | 0d |  |  | OK | 1.2.1.20 | PROC | PROC |
| PR-MT-Z1-LC-10-0060 |  | NMR 601 - Red Tiles |  | 6d | 2016-11-09 | 2016-11-16 | PR-MT-Z1-LC-10-0050 | 183.8d | 0d |  |  | OK | 1.2.1.20 | PROC | PROC |
| PR-MT-Z1-LC-10-0070 |  | NMR 602 - Red Tiles |  | 6d | 2016-11-16 | 2016-11-23 | PR-MT-Z1-LC-10-0060 | 183.8d | 0d |  |  | OK | 1.2.1.20 | PROC | PROC |
| PR-MT-Z1-LC-10-0080 |  | Start of Material Delivery - Red Tiles | milestone | 0d | 2017-01-15 | 2017-01-15 | PR-MT-Z1-LC-10-0070 FS+45d | 183.8d | 0d |  |  | OK | 1.2.1.20 | PROC | PROC |
| PR-MT-Z1-LC-10-0090 |  | Complete Material Delivery - Red Tiles |  | 30d | 2017-01-15 | 2017-02-19 | PR-MT-Z1-LC-10-0080 | 183.8d | 176d | Red Tiles [40850 ea] | 150,070.12 | OK | 1.2.1.20 | PROC | PROC |
|  | 3 | **Communication manhole and Conduit System** |  |  | 2016-09-03 | 2017-03-09 |  |  |  |  |  |  |  |  |  |
|  | 1 | **Ground Cable and Accessories** |  |  | 2016-09-03 | 2017-03-09 |  |  |  |  |  |  |  |  |  |
| PR-MT-Z1-LC-11-0010 |  | RFQ - Grounding Cable & Accessories |  | 7d | 2016-09-03 | 2016-09-15 | PROC-GE-GE-GE-0010 FS+21d | 82.8d | 0d |  |  | OK | 1.2.1.30 | PROC | PROC |
| PR-MT-Z1-LC-11-0020 |  | Material Submittal - Grounding Cable & Accessories |  | 10d | 2016-09-15 | 2016-09-27 | PR-MT-Z1-LC-11-0010 | 82.8d | 0d |  |  | OK | 1.2.1.30 | PROC | PROC |
| PR-MT-Z1-LC-11-0030 |  | Material Approval - Grounding Cable & Accessories |  | 14d | 2016-09-27 | 2016-10-13 | PR-MT-Z1-LC-11-0020 | 82.8d | 0d |  |  | OK | 1.2.1.30 | PROC | PROC |
| PR-MT-Z1-LC-11-0040 |  | Technical Evaluation - Grounding Cable & Accessories |  | 10d | 2016-10-13 | 2016-10-25 | PR-MT-Z1-LC-11-0030 | 82.8d | 0d |  |  | OK | 1.2.1.30 | PROC | PROC |
| PR-MT-Z1-LC-11-0050 |  | PO - Grounding Cable & Accessories |  | 14d | 2016-10-25 | 2016-11-10 | PR-MT-Z1-LC-11-0040 | 82.8d | 0d |  |  | OK | 1.2.1.30 | PROC | PROC |
| PR-MT-Z1-LC-11-0060 |  | NMR 601 - Grounding Cable & Accessories |  | 6d | 2016-11-10 | 2016-11-17 | PR-MT-Z1-LC-11-0050 | 271.8d | 0d |  |  | OK | 1.2.1.30 | PROC | PROC |
| PR-MT-Z1-LC-11-0070 |  | NMR 602 - Grounding Cable & Accessories |  | 6d | 2016-11-17 | 2016-11-24 | PR-MT-Z1-LC-11-0060 | 271.8d | 0d |  |  | OK | 1.2.1.30 | PROC | PROC |
| PR-MT-Z1-LC-11-0080 |  | Start of Material Delivery - Grounding Cable & Accessories | milestone | 0d | 2017-02-08 | 2017-02-08 | PR-MT-Z1-LC-11-0070 FS+65d | 271.8d | 0d |  |  | OK | 1.2.1.30 | PROC | PROC |
| PR-MT-Z1-LC-11-0090 |  | Complete Material Delivery - Grounding Cable & Accessories |  | 15d | 2017-02-08 | 2017-02-26 | PR-MT-Z1-LC-11-0080 | 271.8d | 0d | Ground Cable and Accessories [1 Lm] | 5,989.43 | OK | 1.2.1.30 | PROC | PROC |
| PR-MT-Z1-LC-11-0100 |  | NMR 603 - Grounding Cable & Accessories |  | 10d | 2017-02-26 | 2017-03-09 | PR-MT-Z1-LC-11-0090 | 271.8d | 189.6d |  |  | OK | 1.2.1.30 | PROC | PROC |

Notes:
- PR-MT-Z1-LC-09-0090: Expenses: (New Expense Item) 30014
- PR-MT-Z1-LC-10-0090: Expenses: (New Expense Item) 150070
- PR-MT-Z1-LC-11-0090: Expenses: (New Expense Item) 5989.43

| ID | WBS | Activity | Type | Duration | Start | Finish | Predecessors | Total float | Free float | Resources | Cost | Wajid | RPI_P2 - BOQ ITEMS | RPI_P2 - PROCUREMENT | RPI_P2 - PHASE |
| --- | --- | --- | --- | --- | --- | --- | --- | --- | --- | --- | --- | --- | --- | --- | --- |
|  | 2 | **Manhole Frame & Covers** |  |  | 2016-09-18 | 2017-02-08 |  |  |  |  |  |  |  |  |  |
| PR-MT-Z1-LC-12-0010 |  | RFQ - Manhole Frame & Covers |  | 7d | 2016-09-18 | 2016-09-26 | PROC-GE-GE-GE-0010 FS+30d | 73.8d | 0d |  |  | OK | 1.2.1.30 | PROC | PROC |
| PR-MT-Z1-LC-12-0020 |  | Material Submittal - Manhole Frame & Covers |  | 10d | 2016-09-26 | 2016-10-08 | PR-MT-Z1-LC-12-0010 | 73.8d | 0d |  |  | OK | 1.2.1.30 | PROC | PROC |
| PR-MT-Z1-LC-12-0030 |  | Material Approval - Manhole Frame & Covers |  | 14d | 2016-10-08 | 2016-10-24 | PR-MT-Z1-LC-12-0020 | 73.8d | 0d |  |  | OK | 1.2.1.30 | PROC | PROC |
| PR-MT-Z1-LC-12-0040 |  | Technical Evaluation - Manhole Frame & Covers |  | 10d | 2016-10-24 | 2016-11-05 | PR-MT-Z1-LC-12-0030 | 73.8d | 0d |  |  | OK | 1.2.1.30 | PROC | PROC |
| PR-MT-Z1-LC-12-0050 |  | PO - Manhole Frame & Covers |  | 14d | 2016-11-05 | 2016-11-21 | PR-MT-Z1-LC-12-0040 | 73.8d | 0d |  |  | OK | 1.2.1.30 | PROC | PROC |
| PR-MT-Z1-LC-12-0060 |  | NMR 601 - Manhole Frame & Covers |  | 6d | 2016-11-21 | 2016-11-28 | PR-MT-Z1-LC-12-0050 | 296.8d | 0d |  |  | OK | 1.2.1.30 | PROC | PROC |
| PR-MT-Z1-LC-12-0070 |  | NMR 602 - Manhole Frame & Covers |  | 6d | 2016-11-28 | 2016-12-05 | PR-MT-Z1-LC-12-0060 | 296.8d | 0d |  |  | OK | 1.2.1.30 | PROC | PROC |
| PR-MT-Z1-LC-12-0080 |  | Start of Material Delivery - Manhole Frame & Covers | milestone | 0d | 2016-12-24 | 2016-12-24 | PR-MT-Z1-LC-12-0070 FS+16d | 296.8d | 0d |  |  | OK | 1.2.1.30 | PROC | PROC |
| PR-MT-Z1-LC-12-0090 |  | Complete Material Delivery - Manhole Frame & Covers |  | 30d | 2016-12-24 | 2017-01-28 | PR-MT-Z1-LC-12-0080 | 296.8d | 0d | Manhole Frame & Covers [6 ea] | 2,988.66 | OK | 1.2.1.30 | PROC | PROC |
| PR-MT-Z1-LC-12-0100 |  | NMR 603 - Manhole Frame & Covers |  | 10d | 2017-01-28 | 2017-02-08 | PR-MT-Z1-LC-12-0090 | 296.8d | 214.6d |  |  | OK | 1.2.1.30 | PROC | PROC |
|  | 4 | **Miscellaneous Communication Items** |  |  | 2016-08-31 | 2017-02-25 |  |  |  |  |  |  |  |  |  |
|  | 1 | **PVC Sub-ducts** |  |  | 2016-08-31 | 2017-02-13 |  |  |  |  |  |  |  |  |  |
| PR-MT-Z1-LC-13-0010 |  | RFQ - PVC Sub-ducts |  | 7d | 2016-08-31 | 2016-09-08 | PROC-GE-GE-GE-0010 FS+19.2d | 1.2d | 0d |  |  | OK | 1.2.1.40 | PROC | PROC |
| PR-MT-Z1-LC-13-0020 |  | Material Submittal - PVC Sub-ducts |  | 10d | 2016-09-08 | 2016-09-25 | PR-MT-Z1-LC-13-0010 | 27.6d | 0d |  |  | OK | 1.2.1.40 | PROC | PROC |
| PR-MT-Z1-LC-13-0030 |  | Material Approval - PVC Sub-ducts |  | 14d | 2016-09-25 | 2016-10-11 | PR-MT-Z1-LC-13-0020 | 27.6d | 0d |  |  | OK | 1.2.1.40 | PROC | PROC |
| PR-MT-Z1-LC-13-0040 |  | Technical Evaluation - PVC Sub-ducts |  | 10d | 2016-10-11 | 2016-10-23 | PR-MT-Z1-LC-13-0030 | 27.6d | 0d |  |  | OK | 1.2.1.40 | PROC | PROC |
| PR-MT-Z1-LC-13-0050 |  | PO - PVC Sub-ducts |  | 14d | 2016-10-23 | 2016-11-08 | PR-MT-Z1-LC-13-0040 | 27.6d | 0d |  |  | OK | 1.2.1.40 | PROC | PROC |
| PR-MT-Z1-LC-13-0060 |  | NMR 601 - PVC Sub-ducts |  | 6d | 2016-11-08 | 2016-11-15 | PR-MT-Z1-LC-13-0050 | 27.6d | 0d |  |  | OK | 1.2.1.40 | PROC | PROC |
| PR-MT-Z1-LC-13-0070 |  | NMR 602 - PVC Sub-ducts |  | 6d | 2016-11-15 | 2016-11-22 | PR-MT-Z1-LC-13-0060 | 27.6d | 0d |  |  | OK | 1.2.1.40 | PROC | PROC |
| PR-MT-Z1-LC-13-0080 |  | Start of Material Delivery - PVC Sub-ducts | milestone | 0d | 2017-01-26 | 2017-01-26 | PR-MT-Z1-LC-13-0070 FS+56d | 27.6d | 0d |  |  | OK | 1.2.1.40 | PROC | PROC |
| PR-MT-Z1-LC-13-0090 |  | Complete Material Delivery - PVC Sub-ducts |  | 15d | 2017-01-26 | 2017-02-13 | PR-MT-Z1-LC-13-0080 | 27.6d | 22.8d | PVC Sub-ducts [2194 Lm] | 25,059.12 | OK | 1.2.1.40 | PROC | PROC |
|  | 2 | **Sub-ducts Plugging** |  |  | 2016-08-31 | 2017-02-25 |  |  |  |  |  |  |  |  |  |
| PR-MT-Z1-LC-14-0010 |  | RFQ - Sub-ducts Plugging |  | 7d | 2016-08-31 | 2016-09-08 | PROC-GE-GE-GE-0010 FS+19.2d | 84.6d | 0d |  |  | OK | 1.2.1.40 | PROC | PROC |
| PR-MT-Z1-LC-14-0020 |  | Material Submittal - Sub-ducts Plugging |  | 10d | 2016-09-08 | 2016-09-25 | PR-MT-Z1-LC-14-0010 | 84.6d | 0d |  |  | OK | 1.2.1.40 | PROC | PROC |
| PR-MT-Z1-LC-14-0030 |  | Material Approval - Sub-ducts Plugging |  | 14d | 2016-09-25 | 2016-10-11 | PR-MT-Z1-LC-14-0020 | 84.6d | 0d |  |  | OK | 1.2.1.40 | PROC | PROC |
| PR-MT-Z1-LC-14-0040 |  | Technical Evaluation - Sub-ducts Plugging |  | 10d | 2016-10-11 | 2016-10-23 | PR-MT-Z1-LC-14-0030 | 84.6d | 0d |  |  | OK | 1.2.1.40 | PROC | PROC |
| PR-MT-Z1-LC-14-0050 |  | PO - Sub-ducts Plugging |  | 14d | 2016-10-23 | 2016-11-08 | PR-MT-Z1-LC-14-0040 | 84.6d | 0d |  |  | OK | 1.2.1.40 | PROC | PROC |
| PR-MT-Z1-LC-14-0060 |  | NMR 601 - Sub-ducts Plugging |  | 6d | 2016-11-08 | 2016-11-15 | PR-MT-Z1-LC-14-0050 | 282.6d | 0d |  |  | OK | 1.2.1.40 | PROC | PROC |
| PR-MT-Z1-LC-14-0070 |  | NMR 602 - Sub-ducts Plugging |  | 6d | 2016-11-15 | 2016-11-22 | PR-MT-Z1-LC-14-0060 | 282.6d | 0d |  |  | OK | 1.2.1.40 | PROC | PROC |
| PR-MT-Z1-LC-14-0080 |  | Start of Material Delivery - Sub-ducts Plugging | milestone | 0d | 2017-01-26 | 2017-01-26 | PR-MT-Z1-LC-14-0070 FS+56d | 282.6d | 0d |  |  | OK | 1.2.1.40 | PROC | PROC |
| PR-MT-Z1-LC-14-0090 |  | Complete Material Delivery - Sub-ducts Plugging |  | 15d | 2017-01-26 | 2017-02-13 | PR-MT-Z1-LC-14-0080 | 282.6d | 0d | Sub-ducts Plugging [9 ea] | 4,283.12 | OK | 1.2.1.40 | PROC | PROC |
| PR-MT-Z1-LC-14-0100 |  | NMR 603 - Sub-ducts Plugging |  | 10d | 2017-02-13 | 2017-02-25 | PR-MT-Z1-LC-14-0090 | 282.6d | 200.4d |  |  | OK | 1.2.1.40 | PROC | PROC |

Notes:
- PR-MT-Z1-LC-12-0090: Expenses: (New Expense Item) 2988.66
- PR-MT-Z1-LC-13-0090: Expenses: (New Expense Item) 25059.1
- PR-MT-Z1-LC-14-0090: Expenses: (New Expense Item) 4283.12

| ID | WBS | Activity | Type | Duration | Start | Finish | Predecessors | Total float | Free float | Resources | Cost | Wajid | RPI_P2 - BOQ ITEMS | RPI_P2 - PROCUREMENT | RPI_P2 - PHASE |
| --- | --- | --- | --- | --- | --- | --- | --- | --- | --- | --- | --- | --- | --- | --- | --- |
|  | 2 | **LANDSCAPING WORKS - (MATERIAL)** |  |  | 2016-12-03 | 2017-08-27 |  |  |  |  |  |  |  |  |  |
|  | 1 | **All Palm Trees and Soft landscaping Materials** |  |  | 2016-12-03 | 2017-08-27 |  |  |  |  |  |  |  |  |  |
|  | 1 | **Palm Trees & Soft Landscaping Material** |  |  | 2016-12-03 | 2017-08-27 |  |  |  |  |  |  |  |  |  |
| PR-LW-Z2-GE-15-0010 |  | RFQ - Palm Tree & Soft Scaping Material |  | 7d | 2016-12-03 | 2016-12-11 | PROC-GE-GE-GE-0010 FS+95.2d | 129.6d | 0d |  |  | OK | 1.2.2.10 | PROC | PROC |
| PR-LW-Z2-GE-15-0020 |  | Material Submittal - Palm Tree & Soft Scaping Material |  | 10d | 2016-12-11 | 2016-12-22 | PR-LW-Z2-GE-15-0010 | 129.6d | 0d |  |  | OK | 1.2.2.10 | PROC | PROC |
| PR-LW-Z2-GE-15-0030 |  | Material Approval - Palm Tree & Soft Scaping Material |  | 14d | 2016-12-22 | 2017-01-08 | PR-LW-Z2-GE-15-0020 | 129.6d | 0d |  |  | OK | 1.2.2.10 | PROC | PROC |
| PR-LW-Z2-GE-15-0040 |  | Technical Evaluation - Palm Tree & Soft Scaping Material |  | 10d | 2017-01-08 | 2017-01-19 | PR-LW-Z2-GE-15-0030 | 129.6d | 0d |  |  | OK | 1.2.2.10 | PROC | PROC |
| PR-LW-Z2-GE-15-0050 |  | PO - Palm Tree & Soft Scaping Material |  | 14d | 2017-01-19 | 2017-02-05 | PR-LW-Z2-GE-15-0040 | 129.6d | 0d |  |  | OK | 1.2.2.10 | PROC | PROC |
| PR-LW-Z2-GE-15-0060 |  | NMR 601 - Palm Tree & Soft Scaping Material |  | 6d | 2017-02-05 | 2017-02-12 | PR-LW-Z2-GE-15-0050 | 129.6d | 0d |  |  | OK | 1.2.2.10 | PROC | PROC |
| PR-LW-Z2-GE-15-0070 |  | NMR 602 - Palm Tree & Soft Scaping Material |  | 6d | 2017-02-12 | 2017-02-19 | PR-LW-Z2-GE-15-0060 | 129.6d | 0d |  |  | OK | 1.2.2.10 | PROC | PROC |
| PR-LW-Z2-GE-15-0080 |  | Start of Material Delivery - Palm Tree & Soft Scaping Material | milestone | 0d | 2017-06-01 | 2017-06-01 | PR-LW-Z2-GE-15-0070 FS+88d | 129.6d | 0d |  |  | OK | 1.2.2.10 | PROC | PROC |
| PR-LW-Z2-GE-15-0090 |  | Complete Material Delivery - Palm Tree & Soft Scaping Material |  | 60d | 2017-06-01 | 2017-08-15 | PR-LW-Z2-GE-15-0080 | 129.6d | 0d |  | 125,239.29 | OK | 1.2.2.10 | PROC | PROC |
| PR-LW-Z2-GE-15-0100 |  | NMR 603 - Palm Tree & Soft Scaping Material |  | 10d | 2017-08-15 | 2017-08-27 | PR-LW-Z2-GE-15-0090 | 129.6d | 47.4d |  |  | OK | 1.2.2.10 | PROC | PROC |
|  | 2 | **MATERIAL FOR ZONE - 3** |  |  | 2016-08-09 | 2017-10-26 |  |  |  |  |  |  |  |  |  |
|  | 1 | **CIVIL WORKS - (MATERIAL)** |  |  | 2016-08-17 | 2017-09-17 |  |  |  |  |  |  |  |  |  |
|  | 1 | **Road Works Related Materials** |  |  | 2016-08-28 | 2017-09-17 |  |  |  |  |  |  |  |  |  |
|  | 1 | **Geogrid** |  |  | 2016-08-28 | 2017-04-03 |  |  |  |  |  |  |  |  |  |
| PR-Z3-CW-RW-16-0010 |  | RFQ - Geogrid |  | 7d | 2016-08-28 | 2016-09-04 | PROC-GE-GE-GE-0010 FS+16d | 87.8d | 0d |  |  | OK | 1.2.3.10 | PROC | PROC |
| PR-Z3-CW-RW-16-0020 |  | Material Submittal - Geogrid |  | 10d | 2016-09-05 | 2016-09-21 | PR-Z3-CW-RW-16-0010 | 87.8d | 0d |  |  | OK | 1.2.3.10 | PROC | PROC |
| PR-Z3-CW-RW-16-0030 |  | Material Approval - Geogrid |  | 14d | 2016-09-21 | 2016-10-08 | PR-Z3-CW-RW-16-0020 | 87.8d | 0d |  |  | OK | 1.2.3.10 | PROC | PROC |
| PR-Z3-CW-RW-16-0040 |  | Technical Evaluation - Geogrid |  | 10d | 2016-10-08 | 2016-10-19 | PR-Z3-CW-RW-16-0030 | 87.8d | 0d |  |  | OK | 1.2.3.10 | PROC | PROC |
| PR-Z3-CW-RW-16-0050 |  | PO - Geogrid |  | 14d | 2016-10-19 | 2016-11-05 | PR-Z3-CW-RW-16-0040 | 87.8d | 0d |  |  | OK | 1.2.3.10 | PROC | PROC |
| PR-Z3-CW-RW-16-0060 |  | NMR 601 - Geogrid |  | 6d | 2016-11-05 | 2016-11-12 | PR-Z3-CW-RW-16-0050 | 215.8d | 0d |  |  | OK | 1.2.3.10 | PROC | PROC |
| PR-Z3-CW-RW-16-0070 |  | NMR 602 - Geogrid |  | 6d | 2016-11-12 | 2016-11-19 | PR-Z3-CW-RW-16-0060 | 215.8d | 0d |  |  | OK | 1.2.3.10 | PROC | PROC |
| PR-Z3-CW-RW-16-0080 |  | Start of Material Delivery - Geogrid | milestone | 0d | 2016-12-07 | 2016-12-07 | PR-Z3-CW-RW-16-0070 FS+16d | 215.8d | 0d |  |  | OK | 1.2.3.10 | PROC | PROC |
| PR-Z3-CW-RW-16-0090 |  | Complete Material Delivery - Geogrid |  | 90d | 2016-12-07 | 2017-03-22 | PR-Z3-CW-RW-16-0080 | 250.8d | 0d | Geogrid [3650 Sqm] | 37,126.95 | OK | 1.2.3.10 | PROC | PROC |
| PR-Z3-CW-RW-16-0100 |  | NMR 603 - Geogrid |  | 10d | 2017-03-22 | 2017-04-03 | PR-Z3-CW-RW-16-0090 | 250.8d | 168.6d |  |  | OK | 1.2.3.10 | PROC | PROC |

Notes:
- PR-LW-Z2-GE-15-0090: Expenses: (New Expense Item) 125239
- PR-Z3-CW-RW-16-0090: Expenses: (New Expense Item) 37126.9

| ID | WBS | Activity | Type | Duration | Start | Finish | Predecessors | Total float | Free float | Resources | Cost | Wajid | RPI_P2 - BOQ ITEMS | RPI_P2 - PROCUREMENT | RPI_P2 - PHASE |
| --- | --- | --- | --- | --- | --- | --- | --- | --- | --- | --- | --- | --- | --- | --- | --- |
|  | 2 | **Geotextile Fabric** |  |  | 2016-09-05 | 2017-03-05 |  |  |  |  |  |  |  |  |  |
| PR-Z3-CW-RW-17-0010 |  | RFQ - Geotextile Fabric |  | 7d | 2016-09-05 | 2016-09-18 | PROC-GE-GE-GE-0010 FS+23.2d | 94.6d | 0d |  |  | OK | 1.2.3.10 | PROC | PROC |
| PR-Z3-CW-RW-17-0020 |  | Material Submittal - Geotextile Fabric |  | 7d | 2016-09-18 | 2016-09-26 | PR-Z3-CW-RW-17-0010 | 94.6d | 0d |  |  | OK | 1.2.3.10 | PROC | PROC |
| PR-Z3-CW-RW-17-0030 |  | Material Approval - Geotextile Fabric |  | 10d | 2016-09-26 | 2016-10-08 | PR-Z3-CW-RW-17-0020 | 94.6d | 0d |  |  | OK | 1.2.3.10 | PROC | PROC |
| PR-Z3-CW-RW-17-0040 |  | Technical Evaluation - Geotextile Fabric |  | 7d | 2016-10-08 | 2016-10-16 | PR-Z3-CW-RW-17-0030 | 94.6d | 0d |  |  | OK | 1.2.3.10 | PROC | PROC |
| PR-Z3-CW-RW-17-0050 |  | PO - Geotextile Fabric |  | 10d | 2016-10-16 | 2016-10-27 | PR-Z3-CW-RW-17-0040 | 94.6d | 0d |  |  | OK | 1.2.3.10 | PROC | PROC |
| PR-Z3-CW-RW-17-0060 |  | NMR 601 - Geotextile Fabric |  | 5d | 2016-10-27 | 2016-11-02 | PR-Z3-CW-RW-17-0050 | 240.6d | 0d |  |  | OK | 1.2.3.10 | PROC | PROC |
| PR-Z3-CW-RW-17-0070 |  | NMR 602 - Geotextile Fabric |  | 5d | 2016-11-02 | 2016-11-08 | PR-Z3-CW-RW-17-0060 | 240.6d | 0d |  |  | OK | 1.2.3.10 | PROC | PROC |
| PR-Z3-CW-RW-17-0080 |  | Start of Material Delivery - Geotextile Fabric | milestone | 0d | 2016-11-08 | 2016-11-08 | PR-Z3-CW-RW-17-0070 | 240.6d | 0d |  |  | OK | 1.2.3.10 | PROC | PROC |
| PR-Z3-CW-RW-17-0090 |  | Complete Material Delivery - Geotextile Fabric |  | 90d | 2016-11-08 | 2017-02-21 | PR-Z3-CW-RW-17-0080 | 275.6d | 0d | Geotextile Fabric [28646.8 Sqm] | 230,477.21 | OK | 1.2.3.10 | PROC | PROC |
| PR-Z3-CW-RW-17-0100 |  | NMR 603 - Geotextile Fabric |  | 10d | 2017-02-21 | 2017-03-05 | PR-Z3-CW-RW-17-0090 | 275.6d | 193.4d |  |  | OK | 1.2.3.10 | PROC | PROC |
|  | 3 | **Sub-base (Class- B) & Aggregate Base Course** |  |  | 2016-11-10 | 2017-09-17 |  |  |  |  |  |  |  |  |  |
| PR-Z3-CW-RW-18-0010 |  | RFQ - Sub-base (Class- B) & Aggregate Base Course |  | 7d | 2016-11-10 | 2016-11-19 | PROC-GE-GE-GE-0010 FS+76d | 115.8d | 0d |  |  | OK | 1.2.3.10 | PROC | PROC |
| PR-Z3-CW-RW-18-0020 |  | Material Submittal - Sub-base (Class- B) & Aggregate Base Course |  | 10d | 2016-11-19 | 2016-11-30 | PR-Z3-CW-RW-18-0010 | 115.8d | 0d |  |  | OK | 1.2.3.10 | PROC | PROC |
| PR-Z3-CW-RW-18-0030 |  | Material Approval - Sub-base (Class- B) & Aggregate Base Course |  | 14d | 2016-11-30 | 2016-12-17 | PR-Z3-CW-RW-18-0020 | 115.8d | 0d |  |  | OK | 1.2.3.10 | PROC | PROC |
| PR-Z3-CW-RW-18-0040 |  | Technical Evaluation - Sub-base (Class- B) & Aggregate Base Course |  | 10d | 2016-12-17 | 2016-12-28 | PR-Z3-CW-RW-18-0030 | 115.8d | 0d |  |  | OK | 1.2.3.10 | PROC | PROC |
| PR-Z3-CW-RW-18-0050 |  | PO - Sub-base (Class- B) & Aggregate Base Course |  | 14d | 2016-12-28 | 2017-01-14 | PR-Z3-CW-RW-18-0040 | 115.8d | 0d |  |  | OK | 1.2.3.10 | PROC | PROC |
| PR-Z3-CW-RW-18-0060 |  | NMR 601 - Sub-base (Class- B) & Aggregate Base Course |  | 6d | 2017-01-14 | 2017-01-21 | PR-Z3-CW-RW-18-0050 | 115.8d | 0d |  |  | OK | 1.2.3.10 | PROC | PROC |
| PR-Z3-CW-RW-18-0070 |  | NMR 602 - Sub-base (Class- B) & Aggregate Base Course |  | 6d | 2017-01-21 | 2017-01-28 | PR-Z3-CW-RW-18-0060 | 115.8d | 0d |  |  | OK | 1.2.3.10 | PROC | PROC |
| PR-Z3-CW-RW-18-0080 |  | Start of Material Delivery - Sub-base (Class- B) & Aggregate Base Course | milestone | 0d | 2017-02-05 | 2017-02-05 | PR-Z3-CW-RW-18-0070 FS+7d | 115.8d | 0d |  |  | OK | 1.2.3.10 | PROC | PROC |
| PR-Z3-CW-RW-18-0090 |  | Complete Material Delivery - Sub-base (Class- B) & Aggregate Base Course |  | 180d | 2017-02-05 | 2017-09-12 | PR-Z3-CW-RW-18-0080 | 115.8d | 0d | Sub-base (Class -B) [25646 Cum]; Aggregate Base Course [28586 Sqm] | 1,493,088.74 | OK | 1.2.3.10 | PROC | PROC |
| PR-Z3-CW-RW-18-0100 |  | NMR 603 - Sub-base (Class- B) & Aggregate Base Course |  | 4d | 2017-09-12 | 2017-09-17 | PR-Z3-CW-RW-18-0090 | 115.8d | 33.6d |  |  | OK | 1.2.3.10 | PROC | PROC |
|  | 4 | **Asphalt (Binder & Wearing Course including Prime & Tack Coat)** |  |  | 2016-11-03 | 2017-05-04 |  |  |  |  |  |  |  |  |  |
| PR-Z3-CW-RW-19-0010 |  | RFQ - Asphalt (Binder & Wearing Course including Prime & Tack Coat) |  | 7d | 2016-11-03 | 2016-11-12 | PROC-GE-GE-GE-0010 FS+70d | 34.8d | 0d |  |  | OK | 1.2.3.10 | PROC | PROC |
| PR-Z3-CW-RW-19-0020 |  | Material Submittal - Asphalt (Binder & Wearing Course including Prime & Tack Coat) |  | 10d | 2016-11-12 | 2016-11-23 | PR-Z3-CW-RW-19-0010 | 34.8d | 0d |  |  | OK | 1.2.3.10 | PROC | PROC |
| PR-Z3-CW-RW-19-0030 |  | Material Approval - Asphalt (Binder & Wearing Course including Prime & Tack Coat) |  | 14d | 2016-11-23 | 2016-12-10 | PR-Z3-CW-RW-19-0020 | 34.8d | 0d |  |  | OK | 1.2.3.10 | PROC | PROC |
| PR-Z3-CW-RW-19-0040 |  | Technical Evaluation - Asphalt (Binder & Wearing Course including Prime & Tack Coat) |  | 10d | 2016-12-10 | 2016-12-21 | PR-Z3-CW-RW-19-0030 | 34.8d | 0d |  |  | OK | 1.2.3.10 | PROC | PROC |
| PR-Z3-CW-RW-19-0050 |  | PO - Asphalt (Binder & Wearing Course including Prime & Tack Coat) |  | 13d | 2016-12-21 | 2017-01-05 | PR-Z3-CW-RW-19-0040 | 34.8d | 0d |  |  | OK | 1.2.3.10 | PROC | PROC |
| PR-Z3-CW-RW-19-0060 |  | NMR 601 - Asphalt (Binder & Wearing Course including Prime & Tack Coat) |  | 6d | 2017-01-05 | 2017-01-12 | PR-Z3-CW-RW-19-0050 | 146.8d | 0d |  |  | OK | 1.2.3.10 | PROC | PROC |
| PR-Z3-CW-RW-19-0070 |  | NMR 602 - Asphalt (Binder & Wearing Course including Prime & Tack Coat) |  | 6d | 2017-01-12 | 2017-01-19 | PR-Z3-CW-RW-19-0060 | 146.8d | 0d |  |  | OK | 1.2.3.10 | PROC | PROC |
| PR-Z3-CW-RW-19-0080 |  | Start of Material Delivery - Asphalt (Binder & Wearing Course including Prime & Tack Coat) | milestone | 0d | 2017-03-19 | 2017-03-19 | PR-Z3-CW-RW-19-0070 FS+50d | 146.8d | 0d |  |  | OK | 1.2.3.10 | PROC | PROC |
| PR-Z3-CW-RW-19-0090 |  | Complete Material Delivery - Asphalt (Binder & Wearing Course including Prime & Tack Coat) |  | 30d | 2017-03-19 | 2017-04-23 | PR-Z3-CW-RW-19-0080 | 223.8d | 0d | Asphalt [28586.8 Sqm] | 2,519,923.25 | OK | 1.2.3.10 | PROC | PROC |
| PR-Z3-CW-RW-19-0100 |  | NMR 603 - Asphalt (Binder & Wearing Course including Prime & Tack Coat) |  | 10d | 2017-04-23 | 2017-05-04 | PR-Z3-CW-RW-19-0090 | 223.8d | 141.6d |  |  | OK | 1.2.3.10 | PROC | PROC |

Notes:
- PR-Z3-CW-RW-17-0090: Expenses: (New Expense Item) 230477
- PR-Z3-CW-RW-18-0090: Expenses: (New Expense Item) 1493089
- PR-Z3-CW-RW-19-0090: Expenses: (New Expense Item) 2519923

| ID | WBS | Activity | Type | Duration | Start | Finish | Predecessors | Total float | Free float | Resources | Cost | Wajid | RPI_P2 - BOQ ITEMS | RPI_P2 - PROCUREMENT | RPI_P2 - PHASE |
| --- | --- | --- | --- | --- | --- | --- | --- | --- | --- | --- | --- | --- | --- | --- | --- |
|  | 2 | **Concrete Works Related Materials** |  |  | 2016-08-27 | 2017-08-27 |  |  |  |  |  |  |  |  |  |
|  | 1 | **Gravel Mulch - (3m wide Buffer)** |  |  | 2016-11-19 | 2017-06-17 |  |  |  |  |  |  |  |  |  |
| PR-Z3-CW-CW-20-0010 |  | RFQ - Gravel Mulch |  | 7d | 2016-11-19 | 2016-11-27 | PROC-GE-GE-GE-0010 FS+83d | 174.8d | 0d |  |  | OK | 1.2.3.20 | PROC | PROC |
| PR-Z3-CW-CW-20-0020 |  | Material Submittal - Gravel Mulch |  | 10d | 2016-11-27 | 2016-12-08 | PR-Z3-CW-CW-20-0010 | 174.8d | 0d |  |  | OK | 1.2.3.20 | PROC | PROC |
| PR-Z3-CW-CW-20-0030 |  | Material Approval - Gravel Mulch |  | 14d | 2016-12-08 | 2016-12-25 | PR-Z3-CW-CW-20-0020 | 174.8d | 0d |  |  | OK | 1.2.3.20 | PROC | PROC |
| PR-Z3-CW-CW-20-0040 |  | Technical Evaluation - Gravel Mulch |  | 10d | 2016-12-25 | 2017-01-05 | PR-Z3-CW-CW-20-0030 | 174.8d | 0d |  |  | OK | 1.2.3.20 | PROC | PROC |
| PR-Z3-CW-CW-20-0050 |  | PO - Gravel Mulch |  | 14d | 2017-01-05 | 2017-01-22 | PR-Z3-CW-CW-20-0040 | 174.8d | 0d |  |  | OK | 1.2.3.20 | PROC | PROC |
| PR-Z3-CW-CW-20-0060 |  | NMR 601 - Gravel Mulch |  | 6d | 2017-01-22 | 2017-01-29 | PR-Z3-CW-CW-20-0050 | 174.8d | 0d |  |  | OK | 1.2.3.20 | PROC | PROC |
| PR-Z3-CW-CW-20-0070 |  | NMR 602 - Gravel Mulch |  | 6d | 2017-01-29 | 2017-02-05 | PR-Z3-CW-CW-20-0060 | 174.8d | 0d |  |  | OK | 1.2.3.20 | PROC | PROC |
| PR-Z3-CW-CW-20-0080 |  | Start of Material Delivery - Gravel Mulch | milestone | 0d | 2017-03-04 | 2017-03-04 | PR-Z3-CW-CW-20-0070 FS+23d | 174.8d | 0d |  |  | OK | 1.2.3.20 | PROC | PROC |
| PR-Z3-CW-CW-20-0090 |  | Complete Material Delivery - Gravel Mulch |  | 90d | 2017-03-04 | 2017-06-17 | PR-Z3-CW-CW-20-0080 | 186.8d | 104.6d | Gravel & Gravel Mulch, Gravel N0.4 PEA [11700 Sqm] | 124,883.5 | OK | 1.2.3.20 | PROC | PROC |
|  | 2 | **Concrete Curb & Gutter** |  |  | 2016-10-17 | 2017-08-07 |  |  |  |  |  |  |  |  |  |
| PR-Z3-CW-CW-21-0010 |  | RFQ - Concrete Curb & Gutter |  | 7d | 2016-10-17 | 2016-10-25 | PROC-GE-GE-GE-0010 FS+55.2d | 70.2d | 0d |  |  | OK | 1.2.3.20 | PROC | PROC |
| PR-Z3-CW-CW-21-0020 |  | Material Submittal - Concrete Curb & Gutter |  | 10d | 2016-10-25 | 2016-11-06 | PR-Z3-CW-CW-21-0010 | 70.2d | 0d |  |  | OK | 1.2.3.20 | PROC | PROC |
| PR-Z3-CW-CW-21-0030 |  | Material Approval - Concrete Curb & Gutter |  | 14d | 2016-11-06 | 2016-11-22 | PR-Z3-CW-CW-21-0020 | 70.2d | 0d |  |  | OK | 1.2.3.20 | PROC | PROC |
| PR-Z3-CW-CW-21-0040 |  | Technical Evaluation - Concrete Curb & Gutter |  | 10d | 2016-11-22 | 2016-12-04 | PR-Z3-CW-CW-21-0030 | 70.2d | 0d |  |  | OK | 1.2.3.20 | PROC | PROC |
| PR-Z3-CW-CW-21-0050 |  | PO - Concrete Curb & Gutter |  | 14d | 2016-12-04 | 2016-12-20 | PR-Z3-CW-CW-21-0040 | 70.2d | 0d |  |  | OK | 1.2.3.20 | PROC | PROC |
| PR-Z3-CW-CW-21-0060 |  | NMR 601 - Concrete Curb & Gutter |  | 6d | 2016-12-20 | 2016-12-27 | PR-Z3-CW-CW-21-0050, GE-MS-ENG-ENG-0010 | 70.2d | 0d |  |  | OK | 1.2.3.20 | PROC | PROC |
| PR-Z3-CW-CW-21-0070 |  | NMR 602 - Concrete Curb & Gutter |  | 6d | 2016-12-27 | 2017-01-03 | PR-Z3-CW-CW-21-0060 | 70.2d | 0d |  |  | OK | 1.2.3.20 | PROC | PROC |
| PR-Z3-CW-CW-21-0080 |  | Start of Material Delivery - Concrete Curb & Gutter | milestone | 0d | 2017-04-19 | 2017-04-19 | PR-Z3-CW-CW-21-0070 FS+91d | 70.2d | 0d |  |  | OK | 1.2.3.20 | PROC | PROC |
| PR-Z3-CW-CW-21-0090 |  | Complete Material Delivery - Concrete Curb & Gutter |  | 90d | 2017-04-19 | 2017-08-07 | PR-Z3-CW-CW-21-0080 | 146.6d | 64.4d | Curb (Concrete Edger), Curb & Gutter [4084 Lm] | 780,363.21 | OK | 1.2.3.20 | PROC | PROC |
|  | 3 | **Polyethene Sheet** |  |  | 2016-09-01 | 2017-02-01 |  |  |  |  |  |  |  |  |  |
| PR-Z3-CW-CW-22-0010 |  | RFQ - Polythene Sheet |  | 7d | 2016-09-01 | 2016-09-08 | PROC-GE-GE-GE-0010 FS+20d | 169.8d | 0d |  |  | OK | 1.2.3.20 | PROC | PROC |
| PR-Z3-CW-CW-22-0020 |  | Material Submittal - Polythene Sheet |  | 10d | 2016-09-10 | 2016-09-26 | PR-Z3-CW-CW-22-0010 | 169.8d | 0d |  |  | OK | 1.2.3.20 | PROC | PROC |
| PR-Z3-CW-CW-22-0030 |  | Material Approval - Polythene Sheet |  | 14d | 2016-09-26 | 2016-10-12 | PR-Z3-CW-CW-22-0020 | 169.8d | 0d |  |  | OK | 1.2.3.20 | PROC | PROC |
| PR-Z3-CW-CW-22-0040 |  | Technical Evaluation - Polythene Sheet |  | 10d | 2016-10-12 | 2016-10-24 | PR-Z3-CW-CW-22-0030 | 169.8d | 0d |  |  | OK | 1.2.3.20 | PROC | PROC |
| PR-Z3-CW-CW-22-0050 |  | PO - Polythene Sheet |  | 14d | 2016-10-24 | 2016-11-09 | PR-Z3-CW-CW-22-0040 | 169.8d | 0d |  |  | OK | 1.2.3.20 | PROC | PROC |
| PR-Z3-CW-CW-22-0060 |  | NMR 601 - Polythene Sheet |  | 6d | 2016-11-09 | 2016-11-16 | PR-Z3-CW-CW-22-0050 | 169.8d | 0d |  |  | OK | 1.2.3.20 | PROC | PROC |
| PR-Z3-CW-CW-22-0070 |  | NMR 602 - Polythene Sheet |  | 6d | 2016-11-16 | 2016-11-23 | PR-Z3-CW-CW-22-0060 | 169.8d | 0d |  |  | OK | 1.2.3.20 | PROC | PROC |
| PR-Z3-CW-CW-22-0080 |  | Start of Material Delivery - Polythene Sheet | milestone | 0d | 2016-11-23 | 2016-11-23 | PR-Z3-CW-CW-22-0070 | 169.8d | 0d |  |  | OK | 1.2.3.20 | PROC | PROC |
| PR-Z3-CW-CW-22-0090 |  | Complete Material Delivery - Polythene Sheet |  | 60d | 2016-11-23 | 2017-02-01 | PR-Z3-CW-CW-22-0080 | 302.8d | 220.6d | Polyethene Sheet [23800 Sqm] | 61,053.44 | OK | 1.2.3.20 | PROC | PROC |

Notes:
- PR-Z3-CW-CW-20-0090: Expenses: (New Expense Item) 124884
- PR-Z3-CW-CW-21-0090: Expenses: (New Expense Item) 780363
- PR-Z3-CW-CW-22-0090: Expenses: (New Expense Item) 61053.4

| ID | WBS | Activity | Type | Duration | Start | Finish | Predecessors | Total float | Free float | Resources | Cost | Wajid | RPI_P2 - BOQ ITEMS | RPI_P2 - PROCUREMENT | RPI_P2 - PHASE |
| --- | --- | --- | --- | --- | --- | --- | --- | --- | --- | --- | --- | --- | --- | --- | --- |
|  | 4 | **Bituminus Paint** |  |  | 2016-11-05 | 2017-04-03 |  |  |  |  |  |  |  |  |  |
| PR-Z3-CW-CW-23-0010 |  | RFQ - Bituminus Paint |  | 7d | 2016-11-05 | 2016-11-13 | PROC-GE-GE-GE-0010 FS+71.2d | 95.2d | 0d |  |  | OK | 1.2.3.20 | PROC | PROC |
| PR-Z3-CW-CW-23-0020 |  | Material Submittal - Bituminus Paint |  | 10d | 2016-11-13 | 2016-11-24 | PR-Z3-CW-CW-23-0010 | 95.2d | 0d |  |  | OK | 1.2.3.20 | PROC | PROC |
| PR-Z3-CW-CW-23-0030 |  | Material Approval - Bituminus Paint |  | 14d | 2016-11-24 | 2016-12-11 | PR-Z3-CW-CW-23-0020 | 95.2d | 0d |  |  | OK | 1.2.3.20 | PROC | PROC |
| PR-Z3-CW-CW-23-0040 |  | Technical Evaluation - Bituminus Paint |  | 10d | 2016-12-11 | 2016-12-22 | PR-Z3-CW-CW-23-0030 | 95.2d | 0d |  |  | OK | 1.2.3.20 | PROC | PROC |
| PR-Z3-CW-CW-23-0050 |  | PO - Bituminus Paint |  | 14d | 2016-12-22 | 2017-01-08 | PR-Z3-CW-CW-23-0040 | 95.2d | 0d |  |  | OK | 1.2.3.20 | PROC | PROC |
| PR-Z3-CW-CW-23-0060 |  | NMR 601 - Bituminus Paint |  | 6d | 2017-01-08 | 2017-01-15 | PR-Z3-CW-CW-23-0050 | 95.2d | 0d |  |  | OK | 1.2.3.20 | PROC | PROC |
| PR-Z3-CW-CW-23-0070 |  | NMR 602 - Bituminus Paint |  | 6d | 2017-01-15 | 2017-01-22 | PR-Z3-CW-CW-23-0060 | 95.2d | 0d |  |  | OK | 1.2.3.20 | PROC | PROC |
| PR-Z3-CW-CW-23-0080 |  | Start of Material Delivery - Bituminus Paint | milestone | 0d | 2017-02-15 | 2017-02-15 | PR-Z3-CW-CW-23-0070 FS+21d | 95.2d | 0d |  |  | OK | 1.2.3.20 | PROC | PROC |
| PR-Z3-CW-CW-23-0090 |  | Complete Material Delivery - Bituminus Paint |  | 30d | 2017-02-15 | 2017-03-22 | PR-Z3-CW-CW-23-0080 | 250.6d | 0d | Bituminus Paint [8636 Sqm] | 148,411.87 | OK | 1.2.3.20 | PROC | PROC |
| PR-Z3-CW-CW-23-0100 |  | NMR 603 - Bituminus Paint |  | 10d | 2017-03-22 | 2017-04-03 | PR-Z3-CW-CW-23-0090 | 250.6d | 168.4d |  |  | OK | 1.2.3.20 | PROC | PROC |
|  | 5 | **Ready Mix Concrete** |  |  | 2016-08-30 | 2017-08-27 |  |  |  |  |  |  |  |  |  |
| PR-Z3-CW-CW-24-0010 |  | RFQ - Ready Mix Concrete |  | 7d | 2016-08-30 | 2016-09-06 | PROC-GE-GE-GE-0010 FS+18d | 102d | 0d |  |  | OK | 1.2.3.20 | PROC | PROC |
| PR-Z3-CW-CW-24-0020 |  | Material Submittal - Ready Mix Concrete |  | 7d | 2016-09-07 | 2016-09-20 | PR-Z3-CW-CW-24-0010 | 102d | 0d |  |  | OK | 1.2.3.20 | PROC | PROC |
| PR-Z3-CW-CW-24-0030 |  | Material Approval - Ready Mix Concrete |  | 8d | 2016-09-20 | 2016-09-29 | PR-Z3-CW-CW-24-0020 | 102d | 0d |  |  | OK | 1.2.3.20 | PROC | PROC |
| PR-Z3-CW-CW-24-0040 |  | Technical Evaluation - Ready Mix Concrete |  | 6d | 2016-09-29 | 2016-10-06 | PR-Z3-CW-CW-24-0030 | 102d | 0d |  |  | OK | 1.2.3.20 | PROC | PROC |
| PR-Z3-CW-CW-24-0050 |  | PO - Ready Mix Concrete |  | 8d | 2016-10-06 | 2016-10-16 | PR-Z3-CW-CW-24-0040 | 102d | 0d |  |  | OK | 1.2.3.20 | PROC | PROC |
| PR-Z3-CW-CW-24-0060 |  | NMR 601 - Ready Mix Concrete |  | 3d | 2016-10-16 | 2016-10-19 | PR-Z3-CW-CW-24-0050 | 102d | 0d |  |  | OK | 1.2.3.20 | PROC | PROC |
| PR-Z3-CW-CW-24-0070 |  | NMR 602 - Ready Mix Concrete |  | 3d | 2016-10-19 | 2016-10-23 | PR-Z3-CW-CW-24-0060 | 102d | 0d |  |  | OK | 1.2.3.20 | PROC | PROC |
| PR-Z3-CW-CW-24-0080 |  | Start of Material Delivery - Ready Mix Concrete | milestone | 0d | 2016-10-23 | 2016-10-23 | PR-Z3-CW-CW-24-0070 | 102d | 0d |  |  | OK | 1.2.3.20 | PROC | PROC |
| PR-Z3-CW-CW-24-0090 |  | Complete Material Delivery - Ready Mix Concrete |  | 250d | 2016-10-23 | 2017-08-15 | PR-Z3-CW-CW-24-0080 | 129.8d | 0d | Ready Mix Concrete [4062 m³] | 3,330,026.59 | OK | 1.2.3.20 | PROC | PROC |
| PR-Z3-CW-CW-24-0100 |  | NMR 603 - Ready Mix Concrete |  | 10d | 2017-08-15 | 2017-08-27 | PR-Z3-CW-CW-24-0090 | 129.8d | 47.6d |  |  | OK | 1.2.3.20 | PROC | PROC |
|  | 6 | **Steel Reinforcement** |  |  | 2016-08-27 | 2017-05-31 |  |  |  |  |  |  |  |  |  |
| PR-Z3-CW-CW-25-0010 |  | RFQ - Steel Reinforcement |  | 7d | 2016-08-27 | 2016-09-03 | PROC-GE-GE-GE-0010 FS+15d | 150.2d | 0d |  |  | OK | 1.2.3.20 | PROC | PROC |
| PR-Z3-CW-CW-25-0020 |  | Material Submittal - Steel Reinforcement |  | 7d | 2016-09-04 | 2016-09-17 | PR-Z3-CW-CW-25-0010 | 150.2d | 0d |  |  | OK | 1.2.3.20 | PROC | PROC |
| PR-Z3-CW-CW-25-0030 |  | Material Approval - Steel Reinforcement |  | 7d | 2016-09-17 | 2016-09-25 | PR-Z3-CW-CW-25-0020 | 150.2d | 0d |  |  | OK | 1.2.3.20 | PROC | PROC |
| PR-Z3-CW-CW-25-0040 |  | Technical Evaluation - Steel Reinforcement |  | 7d | 2016-09-25 | 2016-10-03 | PR-Z3-CW-CW-25-0030 | 150.2d | 0d |  |  | OK | 1.2.3.20 | PROC | PROC |
| PR-Z3-CW-CW-25-0050 |  | PO - Steel Reinforcement |  | 10d | 2016-10-03 | 2016-10-15 | PR-Z3-CW-CW-25-0040 | 150.2d | 0d |  |  | OK | 1.2.3.20 | PROC | PROC |
| PR-Z3-CW-CW-25-0060 |  | NMR 601 - Steel Reinforcement |  | 3d | 2016-10-15 | 2016-10-18 | PR-Z3-CW-CW-25-0050 | 150.2d | 0d |  |  | OK | 1.2.3.20 | PROC | PROC |
| PR-Z3-CW-CW-25-0070 |  | NMR 602 - Steel Reinforcement |  | 3d | 2016-10-18 | 2016-10-22 | PR-Z3-CW-CW-25-0060 | 150.2d | 0d |  |  | OK | 1.2.3.20 | PROC | PROC |
| PR-Z3-CW-CW-25-0080 |  | Start of Material Delivery - Steel Reinforcement | milestone | 0d | 2016-10-22 | 2016-10-22 | PR-Z3-CW-CW-25-0070 | 150.2d | 0d |  |  | OK | 1.2.3.20 | PROC | PROC |
| PR-Z3-CW-CW-25-0090 |  | Complete Material Delivery - Steel Reinforcement |  | 180d | 2016-10-22 | 2017-05-20 | PR-Z3-CW-CW-25-0080 | 200.8d | 0d | Steel Reinforcement [16974 kg] | 19,795.42 | OK | 1.2.3.20 | PROC | PROC |
| PR-Z3-CW-CW-25-0100 |  | NMR 603 - Steel Reinforcement |  | 10d | 2017-05-20 | 2017-05-31 | PR-Z3-CW-CW-25-0090 | 200.8d | 118.6d |  |  | OK | 1.2.3.20 | PROC | PROC |

Notes:
- PR-Z3-CW-CW-23-0090: Expenses: (New Expense Item) 148412
- PR-Z3-CW-CW-24-0090: Expenses: (New Expense Item) 3330027
- PR-Z3-CW-CW-25-0090: Expenses: (New Expense Item) 19795.4

| ID | WBS | Activity | Type | Duration | Start | Finish | Predecessors | Total float | Free float | Resources | Cost | Wajid | RPI_P2 - BOQ ITEMS | RPI_P2 - PROCUREMENT | RPI_P2 - PHASE |
| --- | --- | --- | --- | --- | --- | --- | --- | --- | --- | --- | --- | --- | --- | --- | --- |
|  | 7 | **Selected Fill (Backfilling)** |  |  | 2016-08-31 | 2017-06-15 |  |  |  |  |  |  |  |  |  |
| PR-Z3-CW-CW-26-0010 |  | RFQ - Selected Fill (Backfilling) |  | 7d | 2016-08-31 | 2016-09-08 | PROC-GE-GE-GE-0010 FS+19.2d | 114.6d | 0d |  |  | OK | 1.2.3.20 | PROC | PROC |
| PR-Z3-CW-CW-26-0020 |  | Material Submittal - Selected Fill (Backfilling) |  | 8d | 2016-09-08 | 2016-09-22 | PR-Z3-CW-CW-26-0010 | 114.6d | 0d |  |  | OK | 1.2.3.20 | PROC | PROC |
| PR-Z3-CW-CW-26-0030 |  | Material Approval - Selected Fill (Backfilling) |  | 10d | 2016-09-22 | 2016-10-04 | PR-Z3-CW-CW-26-0020 | 114.6d | 0d |  |  | OK | 1.2.3.20 | PROC | PROC |
| PR-Z3-CW-CW-26-0040 |  | Technical Evaluation - Selected Fill (Backfilling) |  | 8d | 2016-10-04 | 2016-10-13 | PR-Z3-CW-CW-26-0030 | 114.6d | 0d |  |  | OK | 1.2.3.20 | PROC | PROC |
| PR-Z3-CW-CW-26-0050 |  | PO - Selected Fill (Backfilling) |  | 14d | 2016-10-13 | 2016-10-30 | PR-Z3-CW-CW-26-0040 | 114.6d | 0d |  |  | OK | 1.2.3.20 | PROC | PROC |
| PR-Z3-CW-CW-26-0060 |  | NMR 601 - Selected Fill (Backfilling) |  | 3d | 2016-10-30 | 2016-11-02 | PR-Z3-CW-CW-26-0050 | 114.6d | 0d |  |  | OK | 1.2.3.20 | PROC | PROC |
| PR-Z3-CW-CW-26-0070 |  | NMR 602 - Selected Fill (Backfilling) |  | 3d | 2016-11-02 | 2016-11-06 | PR-Z3-CW-CW-26-0060 | 114.6d | 0d |  |  | OK | 1.2.3.20 | PROC | PROC |
| PR-Z3-CW-CW-26-0080 |  | Start of Material Delivery - Selected Fill (Backfilling) | milestone | 0d | 2016-11-06 | 2016-11-06 | PR-Z3-CW-CW-26-0070 | 114.6d | 0d |  |  | OK | 1.2.3.20 | PROC | PROC |
| PR-Z3-CW-CW-26-0090 |  | Complete Material Delivery - Selected Fill (Backfilling) |  | 180d | 2016-11-06 | 2017-06-04 | PR-Z3-CW-CW-26-0080 | 187.6d | 0d | Selected Fill (Backfilling) [76 Cum] | 139,654.34 | OK | 1.2.3.20 | PROC | PROC |
| PR-Z3-CW-CW-26-0100 |  | NMR 603 - Selected Fill (Backfilling) |  | 10d | 2017-06-04 | 2017-06-15 | PR-Z3-CW-CW-26-0090 | 187.6d | 105.4d |  |  | OK | 1.2.3.20 | PROC | PROC |
|  | 3 | **All Other Miscellaneous Items** |  |  | 2016-08-17 | 2017-06-20 |  |  |  |  |  |  |  |  |  |
|  | 1 | **Material Shedyard Shifting Related Material** |  |  | 2017-01-10 | 2017-04-27 |  |  |  |  |  |  |  |  |  |
| PR-Z3-CW-MS-27-0010 |  | RFQ - Material Shedyard Shifting Related Material |  | 7d | 2017-01-10 | 2017-01-18 | PROC-GE-GE-GE-0010 FS+128d | 229.8d | 0d |  |  | OK | 1.2.3.30 | PROC | PROC |
| PR-Z3-CW-MS-27-0020 |  | Material Submittal - Material Shedyard Shifting Related Material |  | 10d | 2017-01-18 | 2017-01-30 | PR-Z3-CW-MS-27-0010 | 229.8d | 0d |  |  | OK | 1.2.3.30 | PROC | PROC |
| PR-Z3-CW-MS-27-0030 |  | Material Approval - Material Shedyard Shifting Related Material |  | 14d | 2017-01-30 | 2017-02-15 | PR-Z3-CW-MS-27-0020 | 229.8d | 0d |  |  | OK | 1.2.3.30 | PROC | PROC |
| PR-Z3-CW-MS-27-0040 |  | Technical Evaluation - Material Shedyard Shifting Related Material |  | 10d | 2017-02-15 | 2017-02-27 | PR-Z3-CW-MS-27-0030 | 229.8d | 0d |  |  | OK | 1.2.3.30 | PROC | PROC |
| PR-Z3-CW-MS-27-0050 |  | PO - Material Shedyard Shifting Related Material |  | 14d | 2017-02-27 | 2017-03-15 | PR-Z3-CW-MS-27-0040 | 229.8d | 0d |  |  | OK | 1.2.3.30 | PROC | PROC |
| PR-Z3-CW-MS-27-0060 |  | NMR 601 - Material Shedyard Shifting Related Material |  | 6d | 2017-03-15 | 2017-03-22 | PR-Z3-CW-MS-27-0050 | 229.8d | 0d |  |  | OK | 1.2.3.30 | PROC | PROC |
| PR-Z3-CW-MS-27-0070 |  | NMR 602 - Material Shedyard Shifting Related Material |  | 6d | 2017-03-22 | 2017-03-29 | PR-Z3-CW-MS-27-0060 | 229.8d | 0d |  |  | OK | 1.2.3.30 | PROC | PROC |
| PR-Z3-CW-MS-27-0080 |  | Start of Material Delivery - Material Shedyard Shifting Related Material | milestone | 0d | 2017-03-29 | 2017-03-29 | PR-Z3-CW-MS-27-0070 | 229.8d | 0d |  |  | OK | 1.2.3.30 | PROC | PROC |
| PR-Z3-CW-MS-27-0090 |  | Complete Material Delivery - Material Shedyard Shifting Related Material |  | 15d | 2017-03-29 | 2017-04-16 | PR-Z3-CW-MS-27-0080 | 229.8d | 0d |  | 1,290,818.64 | OK | 1.2.3.30 | PROC | PROC |
| PR-Z3-CW-MS-27-0100 |  | NMR 603 - Material Shedyard Shifting Related Material |  | 10d | 2017-04-16 | 2017-04-27 | PR-Z3-CW-MS-27-0090 | 229.8d | 147.6d |  |  | OK | 1.2.3.30 | PROC | PROC |
|  | 2 | **Traffic Signage** |  |  | 2016-11-28 | 2017-06-20 |  |  |  |  |  |  |  |  |  |
| PR-Z3-CW-MS-28-0010 |  | RFQ - Traffic Signage |  | 7d | 2016-11-28 | 2016-12-06 | PROC-GE-GE-GE-0010 FS+91.2d | 102.2d | 0d |  |  | OK | 1.2.3.30 | PROC | PROC |
| PR-Z3-CW-MS-28-0020 |  | Material Submittal - Traffic Signage |  | 10d | 2016-12-06 | 2016-12-18 | PR-Z3-CW-MS-28-0010 | 102.2d | 0d |  |  | OK | 1.2.3.30 | PROC | PROC |
| PR-Z3-CW-MS-28-0030 |  | Material Approval - Traffic Signage |  | 14d | 2016-12-18 | 2017-01-03 | PR-Z3-CW-MS-28-0020 | 102.2d | 0d |  |  | OK | 1.2.3.30 | PROC | PROC |
| PR-Z3-CW-MS-28-0040 |  | Technical Evaluation - Traffic Signage |  | 10d | 2017-01-03 | 2017-01-15 | PR-Z3-CW-MS-28-0030 | 102.2d | 0d |  |  | OK | 1.2.3.30 | PROC | PROC |
| PR-Z3-CW-MS-28-0050 |  | PO - Traffic Signage |  | 14d | 2017-01-15 | 2017-01-31 | PR-Z3-CW-MS-28-0040 | 102.2d | 0d |  |  | OK | 1.2.3.30 | PROC | PROC |
| PR-Z3-CW-MS-28-0060 |  | NMR 601 - Traffic Signage |  | 6d | 2017-01-31 | 2017-02-07 | PR-Z3-CW-MS-28-0050 | 102.2d | 0d |  |  | OK | 1.2.3.30 | PROC | PROC |
| PR-Z3-CW-MS-28-0070 |  | NMR 602 - Traffic Signage |  | 6d | 2017-02-07 | 2017-02-14 | PR-Z3-CW-MS-28-0060 | 102.2d | 0d |  |  | OK | 1.2.3.30 | PROC | PROC |
| PR-Z3-CW-MS-28-0080 |  | Start of Material Delivery - Traffic Signage | milestone | 0d | 2017-05-04 | 2017-05-04 | PR-Z3-CW-MS-28-0070 FS+68d | 102.2d | 0d |  |  | OK | 1.2.3.30 | PROC | PROC |
| PR-Z3-CW-MS-28-0090 |  | Complete Material Delivery - Traffic Signage |  | 30d | 2017-05-04 | 2017-06-08 | PR-Z3-CW-MS-28-0080 | 183.6d | 0d | Traffic Signage [132 ea] | 930,367.71 | OK | 1.2.3.30 | PROC | PROC |
| PR-Z3-CW-MS-28-0100 |  | NMR 603 - Traffic Signage |  | 10d | 2017-06-08 | 2017-06-20 | PR-Z3-CW-MS-28-0090 | 183.6d | 101.4d |  |  | OK | 1.2.3.30 | PROC | PROC |

Notes:
- PR-Z3-CW-CW-26-0090: Expenses: (New Expense Item) 139654
- PR-Z3-CW-MS-27-0090: Expenses: (New Expense Item) 1290819
- PR-Z3-CW-MS-28-0090: Expenses: (New Expense Item) 930368

| ID | WBS | Activity | Type | Duration | Start | Finish | Predecessors | Total float | Free float | Resources | Cost | Wajid | RPI_P2 - BOQ ITEMS | RPI_P2 - PROCUREMENT | RPI_P2 - PHASE |
| --- | --- | --- | --- | --- | --- | --- | --- | --- | --- | --- | --- | --- | --- | --- | --- |
|  | 3 | **Road Marking Paint** |  |  | 2016-11-06 | 2017-03-11 |  |  |  |  |  |  |  |  |  |
| PR-Z3-CW-MS-29-0010 |  | RFQ - Road Marking Paint |  | 7d | 2016-11-06 | 2016-11-14 | PROC-GE-GE-GE-0010 FS+72d | 208.8d | 0d |  |  | OK | 1.2.3.30 | PROC | PROC |
| PR-Z3-CW-MS-29-0020 |  | Material Submittal - Road Marking Paint |  | 10d | 2016-11-14 | 2016-11-26 | PR-Z3-CW-MS-29-0010 | 208.8d | 0d |  |  | OK | 1.2.3.30 | PROC | PROC |
| PR-Z3-CW-MS-29-0030 |  | Material Approval - Road Marking Paint |  | 14d | 2016-11-26 | 2016-12-12 | PR-Z3-CW-MS-29-0020 | 208.8d | 0d |  |  | OK | 1.2.3.30 | PROC | PROC |
| PR-Z3-CW-MS-29-0040 |  | Technical Evaluation - Road Marking Paint |  | 10d | 2016-12-12 | 2016-12-24 | PR-Z3-CW-MS-29-0030 | 208.8d | 0d |  |  | OK | 1.2.3.30 | PROC | PROC |
| PR-Z3-CW-MS-29-0050 |  | PO - Road Marking Paint |  | 14d | 2016-12-24 | 2017-01-09 | PR-Z3-CW-MS-29-0040 | 208.8d | 0d |  |  | OK | 1.2.3.30 | PROC | PROC |
| PR-Z3-CW-MS-29-0060 |  | NMR 601 - Road Marking Paint |  | 6d | 2017-01-09 | 2017-01-16 | PR-Z3-CW-MS-29-0050 | 208.8d | 0d |  |  | OK | 1.2.3.30 | PROC | PROC |
| PR-Z3-CW-MS-29-0070 |  | NMR 602 - Road Marking Paint |  | 6d | 2017-01-16 | 2017-01-23 | PR-Z3-CW-MS-29-0060 | 208.8d | 0d |  |  | OK | 1.2.3.30 | PROC | PROC |
| PR-Z3-CW-MS-29-0080 |  | Start of Material Delivery - Road Marking Paint | milestone | 0d | 2017-01-23 | 2017-01-23 | PR-Z3-CW-MS-29-0070 | 208.8d | 0d |  |  | OK | 1.2.3.30 | PROC | PROC |
| PR-Z3-CW-MS-29-0090 |  | Complete Material Delivery - Road Marking Paint |  | 30d | 2017-01-23 | 2017-02-27 | PR-Z3-CW-MS-29-0080 | 270.8d | 0d | Road Marking Paint [1 Sqm] | 193,381.07 | OK | 1.2.3.30 | PROC | PROC |
| PR-Z3-CW-MS-29-0100 |  | NMR 603 - Road Marking Paint |  | 10d | 2017-02-27 | 2017-03-11 | PR-Z3-CW-MS-29-0090 | 270.8d | 188.6d |  |  | OK | 1.2.3.30 | PROC | PROC |
|  | 4 | **Steel Pipe Bollards (150 mm Dia. Painted Yellow & Black)** |  |  | 2016-10-05 | 2017-04-23 |  |  |  |  |  |  |  |  |  |
| PR-Z3-CW-MS-30-0010 |  | RFQ - Steel Pipe Bollards (150 mm Dia. Painted Yellow & Black) |  | 7d | 2016-10-05 | 2016-10-12 | PROC-GE-GE-GE-0010 FS+44.8d | 233d | 0d |  |  | OK | 1.2.3.30 | PROC | PROC |
| PR-Z3-CW-MS-30-0020 |  | Material Submittal - Steel Pipe Bollards (150 mm Dia. Painted Yellow & Black) |  | 10d | 2016-10-13 | 2016-10-24 | PR-Z3-CW-MS-30-0010 | 233d | 0d |  |  | OK | 1.2.3.30 | PROC | PROC |
| PR-Z3-CW-MS-30-0030 |  | Material Approval - Steel Pipe Bollards (150 mm Dia. Painted Yellow & Black) |  | 14d | 2016-10-25 | 2016-11-09 | PR-Z3-CW-MS-30-0020 | 233d | 0d |  |  | OK | 1.2.3.30 | PROC | PROC |
| PR-Z3-CW-MS-30-0040 |  | Technical Evaluation - Steel Pipe Bollards (150 mm Dia. Painted Yellow & Black) |  | 10d | 2016-11-10 | 2016-11-21 | PR-Z3-CW-MS-30-0030 | 233d | 0d |  |  | OK | 1.2.3.30 | PROC | PROC |
| PR-Z3-CW-MS-30-0050 |  | PO - Steel Pipe Bollards (150 mm Dia. Painted Yellow & Black) |  | 14d | 2016-11-22 | 2016-12-07 | PR-Z3-CW-MS-30-0040 | 233d | 0d |  |  | OK | 1.2.3.30 | PROC | PROC |
| PR-Z3-CW-MS-30-0060 |  | NMR 601 - Steel Pipe Bollards (150 mm Dia. Painted Yellow & Black) |  | 6d | 2016-12-08 | 2016-12-14 | PR-Z3-CW-MS-30-0050 | 233d | 0d |  |  | OK | 1.2.3.30 | PROC | PROC |
| PR-Z3-CW-MS-30-0070 |  | NMR 602 - Steel Pipe Bollards (150 mm Dia. Painted Yellow & Black) |  | 6d | 2016-12-15 | 2016-12-21 | PR-Z3-CW-MS-30-0060 | 233d | 0d |  |  | OK | 1.2.3.30 | PROC | PROC |
| PR-Z3-CW-MS-30-0080 |  | Start of Material Delivery - Steel Pipe Bollards (150 mm Dia. Painted Yellow & Black) | milestone | 0d | 2017-03-26 | 2017-03-26 | PR-Z3-CW-MS-30-0070 FS+80d | 233d | 0d |  |  | OK | 1.2.3.30 | PROC | PROC |
| PR-Z3-CW-MS-30-0090 |  | Complete Material Delivery - Steel Pipe Bollards (150 mm Dia. Painted Yellow & Black) |  | 15d | 2017-03-26 | 2017-04-11 | PR-Z3-CW-MS-30-0080 | 233d | 0d | Steel Pipe Bollards [32 ea] | 32,288.97 | OK | 1.2.3.30 | PROC | PROC |
| PR-Z3-CW-MS-30-0100 |  | NMR 603 - Steel Pipe Bollards (150 mm Dia. Painted Yellow & Black) |  | 10d | 2017-04-12 | 2017-04-23 | PR-Z3-CW-MS-30-0090 | 233d | 150.8d |  |  | OK | 1.2.3.30 | PROC | PROC |
|  | 5 | **Bench & Picnic Tables (Site Furnishing)** |  |  | 2016-12-14 | 2017-06-12 |  |  |  |  |  |  |  |  |  |
| PR-Z3-CW-MS-31-0010 |  | RFQ - Bench & Picnic Tables |  | 7d | 2016-12-14 | 2016-12-21 | PROC-GE-GE-GE-0010 FS+104.8d | 112d | 0d |  |  | OK | 1.2.3.30 | PROC | PROC |
| PR-Z3-CW-MS-31-0020 |  | Material Submittal - Bench & Picnic Tables |  | 10d | 2016-12-22 | 2017-01-02 | PR-Z3-CW-MS-31-0010 | 112d | 0d |  |  | OK | 1.2.3.30 | PROC | PROC |
| PR-Z3-CW-MS-31-0030 |  | Material Approval - Bench & Picnic Tables |  | 14d | 2017-01-03 | 2017-01-18 | PR-Z3-CW-MS-31-0020 | 112d | 0d |  |  | OK | 1.2.3.30 | PROC | PROC |
| PR-Z3-CW-MS-31-0040 |  | Technical Evaluation - Bench & Picnic Tables |  | 10d | 2017-01-19 | 2017-01-30 | PR-Z3-CW-MS-31-0030 | 112d | 0d |  |  | OK | 1.2.3.30 | PROC | PROC |
| PR-Z3-CW-MS-31-0050 |  | PO - Bench & Picnic Tables |  | 14d | 2017-01-31 | 2017-02-15 | PR-Z3-CW-MS-31-0040 | 112d | 0d |  |  | OK | 1.2.3.30 | PROC | PROC |
| PR-Z3-CW-MS-31-0060 |  | NMR 601 - Bench & Picnic Tables |  | 6d | 2017-02-16 | 2017-02-22 | PR-Z3-CW-MS-31-0050 | 112d | 0d |  |  | OK | 1.2.3.30 | PROC | PROC |
| PR-Z3-CW-MS-31-0070 |  | NMR 602 - Bench & Picnic Tables |  | 6d | 2017-02-23 | 2017-03-01 | PR-Z3-CW-MS-31-0060 | 112d | 0d |  |  | OK | 1.2.3.30 | PROC | PROC |
| PR-Z3-CW-MS-31-0080 |  | Start of Material Delivery - Bench & Picnic Tables | milestone | 0d | 2017-05-16 | 2017-05-16 | PR-Z3-CW-MS-31-0070 FS+64d | 112d | 0d |  |  | OK | 1.2.3.30 | PROC | PROC |
| PR-Z3-CW-MS-31-0090 |  | Complete Material Delivery - Bench & Picnic Tables |  | 20d | 2017-05-16 | 2017-06-07 | PR-Z3-CW-MS-31-0080 | 190d | 0d | Bench & Picnic Tables [130 ea] | 519,458.44 | OK | 1.2.3.30 | PROC | PROC |
| PR-Z3-CW-MS-31-0100 |  | NMR 603 - Bench & Picnic Tables |  | 4d | 2017-06-08 | 2017-06-12 | PR-Z3-CW-MS-31-0090 | 190d | 107.8d |  |  | OK | 1.2.3.30 | PROC | PROC |

Notes:
- PR-Z3-CW-MS-29-0090: Expenses: (New Expense Item) 193381
- PR-Z3-CW-MS-30-0090: Expenses: (New Expense Item) 32289
- PR-Z3-CW-MS-31-0090: Expenses: (New Expense Item) 519458

| ID | WBS | Activity | Type | Duration | Start | Finish | Predecessors | Total float | Free float | Resources | Cost | Wajid | RPI_P2 - BOQ ITEMS | RPI_P2 - PROCUREMENT | RPI_P2 - PHASE |
| --- | --- | --- | --- | --- | --- | --- | --- | --- | --- | --- | --- | --- | --- | --- | --- |
|  | 6 | **Drinking Fountains** |  |  | 2016-09-24 | 2017-05-10 |  |  |  |  |  |  |  |  |  |
| PR-Z3-CW-MS-32-0010 |  | RFQ - Drinking Fountains |  | 7d | 2016-09-24 | 2016-10-02 | PROC-GE-GE-GE-0010 FS+35.2d | 139.6d | 0d |  |  | OK | 1.2.3.30 | PROC | PROC |
| PR-Z3-CW-MS-32-0020 |  | Material Submittal - Drinking Fountains |  | 10d | 2016-10-02 | 2016-10-13 | PR-Z3-CW-MS-32-0010 | 139.6d | 0d |  |  | OK | 1.2.3.30 | PROC | PROC |
| PR-Z3-CW-MS-32-0030 |  | Material Approval - Drinking Fountains |  | 14d | 2016-10-13 | 2016-10-30 | PR-Z3-CW-MS-32-0020 | 139.6d | 0d |  |  | OK | 1.2.3.30 | PROC | PROC |
| PR-Z3-CW-MS-32-0040 |  | Technical Evaluation - Drinking Fountains |  | 10d | 2016-10-30 | 2016-11-10 | PR-Z3-CW-MS-32-0030 | 139.6d | 0d |  |  | OK | 1.2.3.30 | PROC | PROC |
| PR-Z3-CW-MS-32-0050 |  | PO - Drinking Fountains |  | 14d | 2016-11-10 | 2016-11-27 | PR-Z3-CW-MS-32-0040 | 139.6d | 0d |  |  | OK | 1.2.3.30 | PROC | PROC |
| PR-Z3-CW-MS-32-0060 |  | NMR 601 - Drinking Fountains |  | 6d | 2016-11-27 | 2016-12-04 | PR-Z3-CW-MS-32-0050 | 139.6d | 0d |  |  | OK | 1.2.3.30 | PROC | PROC |
| PR-Z3-CW-MS-32-0070 |  | NMR 602 - Drinking Fountains |  | 6d | 2016-12-04 | 2016-12-11 | PR-Z3-CW-MS-32-0060 | 139.6d | 0d |  |  | OK | 1.2.3.30 | PROC | PROC |
| PR-Z3-CW-MS-32-0080 |  | Start of Material Delivery - Drinking Fountains | milestone | 0d | 2017-04-11 | 2017-04-11 | PR-Z3-CW-MS-32-0070 FS+104d | 139.6d | 0d |  |  | OK | 1.2.3.30 | PROC | PROC |
| PR-Z3-CW-MS-32-0090 |  | Complete Material Delivery - Drinking Fountains |  | 15d | 2017-04-11 | 2017-04-29 | PR-Z3-CW-MS-32-0080 | 218.6d | 0d | Drinking Fountains [45 ea] | 416,278.34 | OK | 1.2.3.30 | PROC | PROC |
| PR-Z3-CW-MS-32-0100 |  | NMR 603 - Drinking Fountains |  | 10d | 2017-04-29 | 2017-05-10 | PR-Z3-CW-MS-32-0090 | 218.6d | 136.4d |  |  | OK | 1.2.3.30 | PROC | PROC |
|  | 7 | **BBQ Grill with cover** |  |  | 2016-12-14 | 2017-06-13 |  |  |  |  |  |  |  |  |  |
| PR-Z3-CW-MS-33-0010 |  | RFQ - BBQ Grill with cover |  | 7d | 2016-12-14 | 2016-12-21 | PROC-GE-GE-GE-0010 FS+104.8d | 110d | 0d |  |  | OK | 1.2.3.30 | PROC | PROC |
| PR-Z3-CW-MS-33-0020 |  | Material Submittal - BBQ Grill with cover |  | 10d | 2016-12-22 | 2017-01-02 | PR-Z3-CW-MS-33-0010 | 110d | 0d |  |  | OK | 1.2.3.30 | PROC | PROC |
| PR-Z3-CW-MS-33-0030 |  | Material Approval - BBQ Grill with cover |  | 14d | 2017-01-03 | 2017-01-18 | PR-Z3-CW-MS-33-0020 | 110d | 0d |  |  | OK | 1.2.3.30 | PROC | PROC |
| PR-Z3-CW-MS-33-0040 |  | Technical Evaluation - BBQ Grill with cover |  | 10d | 2017-01-19 | 2017-01-30 | PR-Z3-CW-MS-33-0030 | 110d | 0d |  |  | OK | 1.2.3.30 | PROC | PROC |
| PR-Z3-CW-MS-33-0050 |  | PO - BBQ Grill with cover |  | 14d | 2017-01-31 | 2017-02-15 | PR-Z3-CW-MS-33-0040 | 110d | 0d |  |  | OK | 1.2.3.30 | PROC | PROC |
| PR-Z3-CW-MS-33-0060 |  | NMR 601 - BBQ Grill with cover |  | 6d | 2017-02-16 | 2017-02-22 | PR-Z3-CW-MS-33-0050 | 110d | 0d |  |  | OK | 1.2.3.30 | PROC | PROC |
| PR-Z3-CW-MS-33-0070 |  | NMR 602 - BBQ Grill with cover |  | 6d | 2017-02-23 | 2017-03-01 | PR-Z3-CW-MS-33-0060 | 110d | 0d |  |  | OK | 1.2.3.30 | PROC | PROC |
| PR-Z3-CW-MS-33-0080 |  | Start of Material Delivery - BBQ Grill with cover | milestone | 0d | 2017-05-16 | 2017-05-16 | PR-Z3-CW-MS-33-0070 FS+64d | 110d | 0d |  |  | OK | 1.2.3.30 | PROC | PROC |
| PR-Z3-CW-MS-33-0090 |  | Complete Material Delivery - BBQ Grill with cover |  | 15d | 2017-05-16 | 2017-06-01 | PR-Z3-CW-MS-33-0080 | 189d | 0d | BBQ Grill with cover [32 ea] | 34,156.17 | OK | 1.2.3.30 | PROC | PROC |
| PR-Z3-CW-MS-33-0100 |  | NMR 603 - BBQ Grill with cover |  | 10d | 2017-06-03 | 2017-06-13 | PR-Z3-CW-MS-33-0090 | 189d | 106.8d |  |  | OK | 1.2.3.30 | PROC | PROC |
|  | 8 | **Hand wash** |  |  | 2016-12-14 | 2017-06-13 |  |  |  |  |  |  |  |  |  |
| PR-Z3-CW-MS-34-0010 |  | RFQ - Hand Wash |  | 7d | 2016-12-14 | 2016-12-21 | PROC-GE-GE-GE-0010 FS+104.8d | 118d | 0d |  |  | OK | 1.2.3.30 | PROC | PROC |
| PR-Z3-CW-MS-34-0020 |  | Material Submittal - Hand Wash |  | 10d | 2016-12-22 | 2017-01-02 | PR-Z3-CW-MS-34-0010 | 118d | 0d |  |  | OK | 1.2.3.30 | PROC | PROC |
| PR-Z3-CW-MS-34-0030 |  | Material Approval - Hand Wash |  | 14d | 2017-01-03 | 2017-01-18 | PR-Z3-CW-MS-34-0020 | 118d | 0d |  |  | OK | 1.2.3.30 | PROC | PROC |
| PR-Z3-CW-MS-34-0040 |  | Technical Evaluation - Hand Wash |  | 10d | 2017-01-19 | 2017-01-30 | PR-Z3-CW-MS-34-0030 | 118d | 0d |  |  | OK | 1.2.3.30 | PROC | PROC |
| PR-Z3-CW-MS-34-0050 |  | PO - Hand Wash |  | 14d | 2017-01-31 | 2017-02-15 | PR-Z3-CW-MS-34-0040 | 118d | 0d |  |  | OK | 1.2.3.30 | PROC | PROC |
| PR-Z3-CW-MS-34-0060 |  | NMR 601 - Hand Wash |  | 6d | 2017-02-16 | 2017-02-22 | PR-Z3-CW-MS-34-0050 | 118d | 0d |  |  | OK | 1.2.3.30 | PROC | PROC |
| PR-Z3-CW-MS-34-0070 |  | NMR 602 - Hand Wash |  | 6d | 2017-02-23 | 2017-03-01 | PR-Z3-CW-MS-34-0060 | 118d | 0d |  |  | OK | 1.2.3.30 | PROC | PROC |
| PR-Z3-CW-MS-34-0080 |  | Start of Material Delivery - Hand Wash | milestone | 0d | 2017-05-16 | 2017-05-16 | PR-Z3-CW-MS-34-0070 FS+64d | 118d | 0d |  |  | OK | 1.2.3.30 | PROC | PROC |
| PR-Z3-CW-MS-34-0090 |  | Complete Material Delivery - Hand Wash |  | 15d | 2017-05-16 | 2017-06-01 | PR-Z3-CW-MS-34-0080 | 189d | 0d | Hand wash [32 ea] | 113,853.9 | OK | 1.2.3.30 | PROC | PROC |
| PR-Z3-CW-MS-34-0100 |  | NMR 603 - Hand Wash |  | 10d | 2017-06-03 | 2017-06-13 | PR-Z3-CW-MS-34-0090 | 189d | 106.8d |  |  | OK | 1.2.3.30 | PROC | PROC |

Notes:
- PR-Z3-CW-MS-32-0090: Expenses: (New Expense Item) 416278
- PR-Z3-CW-MS-33-0090: Expenses: (New Expense Item) 34156.2
- PR-Z3-CW-MS-34-0090: Expenses: (New Expense Item) 113854

| ID | WBS | Activity | Type | Duration | Start | Finish | Predecessors | Total float | Free float | Resources | Cost | Wajid | RPI_P2 - BOQ ITEMS | RPI_P2 - PROCUREMENT | RPI_P2 - PHASE |
| --- | --- | --- | --- | --- | --- | --- | --- | --- | --- | --- | --- | --- | --- | --- | --- |
|  | 9 | **Trash Receptacle** |  |  | 2016-11-05 | 2017-05-09 |  |  |  |  |  |  |  |  |  |
| PR-Z3-CW-MS-35-0010 |  | RFQ - Trash Receptable |  | 7d | 2016-11-05 | 2016-11-13 | PROC-GE-GE-GE-0010 FS+71.2d | 148.6d | 0d |  |  | OK | 1.2.3.30 | PROC | PROC |
| PR-Z3-CW-MS-35-0020 |  | Material Submittal - Trash Receptable |  | 10d | 2016-11-13 | 2016-11-24 | PR-Z3-CW-MS-35-0010 | 148.6d | 0d |  |  | OK | 1.2.3.30 | PROC | PROC |
| PR-Z3-CW-MS-35-0030 |  | Material Approval - Trash Receptable |  | 14d | 2016-11-24 | 2016-12-11 | PR-Z3-CW-MS-35-0020 | 148.6d | 0d |  |  | OK | 1.2.3.30 | PROC | PROC |
| PR-Z3-CW-MS-35-0040 |  | Technical Evaluation - Trash Receptable |  | 10d | 2016-12-11 | 2016-12-22 | PR-Z3-CW-MS-35-0030 | 148.6d | 0d |  |  | OK | 1.2.3.30 | PROC | PROC |
| PR-Z3-CW-MS-35-0050 |  | PO - Trash Receptable |  | 14d | 2016-12-22 | 2017-01-08 | PR-Z3-CW-MS-35-0040 | 148.6d | 0d |  |  | OK | 1.2.3.30 | PROC | PROC |
| PR-Z3-CW-MS-35-0060 |  | NMR 601 - Trash Receptable |  | 6d | 2017-01-08 | 2017-01-15 | PR-Z3-CW-MS-35-0050 | 148.6d | 0d |  |  | OK | 1.2.3.30 | PROC | PROC |
| PR-Z3-CW-MS-35-0070 |  | NMR 602 - Trash Receptable |  | 6d | 2017-01-15 | 2017-01-22 | PR-Z3-CW-MS-35-0060 | 148.6d | 0d |  |  | OK | 1.2.3.30 | PROC | PROC |
| PR-Z3-CW-MS-35-0080 |  | Start of Material Delivery - Trash Receptable | milestone | 0d | 2017-04-10 | 2017-04-10 | PR-Z3-CW-MS-35-0070 FS+67d | 148.6d | 0d |  |  | OK | 1.2.3.30 | PROC | PROC |
| PR-Z3-CW-MS-35-0090 |  | Complete Material Delivery - Trash Receptable |  | 15d | 2017-04-10 | 2017-04-27 | PR-Z3-CW-MS-35-0080 | 219.6d | 0d | Trash Receptacle [120 ea] | 273,249.37 | OK | 1.2.3.30 | PROC | PROC |
| PR-Z3-CW-MS-35-0100 |  | NMR 603 - Trash Receptable |  | 10d | 2017-04-27 | 2017-05-09 | PR-Z3-CW-MS-35-0090 | 219.6d | 137.4d |  |  | OK | 1.2.3.30 | PROC | PROC |
|  | 10 | **Masonry Block & Accessories** |  |  | 2016-08-28 | 2016-11-21 |  |  |  |  |  |  |  |  |  |
| PR-Z3-GE-GE-215-0010 |  | RFQ - Masonry Block & Accessories |  | 5.6d | 2016-08-28 | 2016-09-03 | PROC-GE-GE-GE-0010 FS+16d | 118.6d | 0d |  |  | OK | 1.2.3.30 | PROC | PROC |
| PR-Z3-GE-GE-215-0020 |  | Material Submittal - Masonry Block & Accessories |  | 8d | 2016-09-03 | 2016-09-17 | PR-Z3-GE-GE-215-0010 | 118.6d | 0d |  |  | OK | 1.2.3.30 | PROC | PROC |
| PR-Z3-GE-GE-215-0030 |  | Material Approval - Masonry Block & Accessories |  | 11.2d | 2016-09-17 | 2016-09-29 | PR-Z3-GE-GE-215-0020 | 118.6d | 0d |  |  | OK | 1.2.3.30 | PROC | PROC |
| PR-Z3-GE-GE-215-0040 |  | Technical Evaluation - Masonry Block & Accessories |  | 8d | 2016-10-01 | 2016-10-09 | PR-Z3-GE-GE-215-0030 | 118.6d | 0d |  |  | OK | 1.2.3.30 | PROC | PROC |
| PR-Z3-GE-GE-215-0050 |  | PO - Masonry Block & Accessories |  | 11.2d | 2016-10-10 | 2016-10-23 | PR-Z3-GE-GE-215-0040 | 118.6d | 0d |  |  | OK | 1.2.3.30 | PROC | PROC |
| PR-Z3-GE-GE-215-0060 |  | NMR 601 - Masonry Block & Accessories |  | 4.8d | 2016-10-23 | 2016-10-27 | PR-Z3-GE-GE-215-0050 | 118.6d | 0d |  |  | OK | 1.2.3.30 | PROC | PROC |
| PR-Z3-GE-GE-215-0070 |  | NMR 602 - Masonry Block & Accessories |  | 4.8d | 2016-10-29 | 2016-11-02 | PR-Z3-GE-GE-215-0060 | 118.6d | 0d |  |  | OK | 1.2.3.30 | PROC | PROC |
| PR-Z3-GE-GE-215-0080 |  | Start of Material Delivery - Masonry Block & Accessories | milestone | 0d | 2016-11-07 | 2016-11-07 | PR-Z3-GE-GE-215-0070 FS+4d | 118.6d | 0d |  |  | OK | 1.2.3.30 | PROC | PROC |
| PR-Z3-GE-GE-215-0090 |  | Complete Material Delivery - Masonry Block & Accessories |  | 12d | 2016-11-07 | 2016-11-21 | PR-Z3-GE-GE-215-0080 | 364.2d | 282d | Masonry Block & Accessories [276.68 Sqm] |  | OK | 1.2.3.30 | PROC | PROC |
|  | 11 | **External Building Signage** |  |  | 2016-11-27 | 2017-04-04 |  |  |  |  |  |  |  |  |  |
| PR-Z3-GE-GE-216-0010 |  | RFQ - External Building Signage |  | 5.6d | 2016-11-27 | 2016-12-04 | PROC-GE-GE-GE-0010 FS+90.4d | 187.8d | 0d |  |  | OK | 1.2.3.30 | PROC | PROC |
| PR-Z3-GE-GE-216-0020 |  | Material Submittal - External Building Signage |  | 8d | 2016-12-04 | 2016-12-13 | PR-Z3-GE-GE-216-0010 | 187.8d | 0d |  |  | OK | 1.2.3.30 | PROC | PROC |
| PR-Z3-GE-GE-216-0030 |  | Material Approval - External Building Signage |  | 11.2d | 2016-12-13 | 2016-12-26 | PR-Z3-GE-GE-216-0020 | 187.8d | 0d |  |  | OK | 1.2.3.30 | PROC | PROC |
| PR-Z3-GE-GE-216-0040 |  | Technical Evaluation - External Building Signage |  | 8d | 2016-12-26 | 2017-01-04 | PR-Z3-GE-GE-216-0030 | 187.8d | 0d |  |  | OK | 1.2.3.30 | PROC | PROC |
| PR-Z3-GE-GE-216-0050 |  | PO - External Building Signage |  | 11.2d | 2017-01-04 | 2017-01-17 | PR-Z3-GE-GE-216-0040 | 187.8d | 0d |  |  | OK | 1.2.3.30 | PROC | PROC |
| PR-Z3-GE-GE-216-0060 |  | NMR 601 - External Building Signage |  | 4.8d | 2017-01-17 | 2017-01-23 | PR-Z3-GE-GE-216-0050 | 187.8d | 0d |  |  | OK | 1.2.3.30 | PROC | PROC |
| PR-Z3-GE-GE-216-0070 |  | NMR 602 - External Building Signage |  | 4.8d | 2017-01-23 | 2017-01-29 | PR-Z3-GE-GE-216-0060 | 187.8d | 0d |  |  | OK | 1.2.3.30 | PROC | PROC |
| PR-Z3-GE-GE-216-0080 |  | Start of Material Delivery - External Building Signage | milestone | 0d | 2017-03-12 | 2017-03-12 | PR-Z3-GE-GE-216-0070 FS+36d | 187.8d | 0d |  |  | OK | 1.2.3.30 | PROC | PROC |
| PR-Z3-GE-GE-216-0090 |  | Complete Material Delivery - External Building Signage |  | 12d | 2017-03-12 | 2017-03-26 | PR-Z3-GE-GE-216-0080 | 249.8d | 0d | External Building Signage [45 ea] |  | OK | 1.2.3.30 | PROC | PROC |
| PR-Z3-GE-GE-216-0100 |  | NMR 603 - External Building Signage |  | 8d | 2017-03-26 | 2017-04-04 | PR-Z3-GE-GE-216-0090 | 249.8d | 167.6d |  |  | OK | 1.2.3.30 | PROC | PROC |

Notes:
- PR-Z3-CW-MS-35-0090: Expenses: (New Expense Item) 273249
- PR-Z3-GE-GE-215-0080: Expenses: (New Expense Item) 0

| ID | WBS | Activity | Type | Duration | Start | Finish | Predecessors | Total float | Free float | Resources | Wajid | RPI_P2 - BOQ ITEMS | RPI_P2 - PROCUREMENT | RPI_P2 - PHASE |
| --- | --- | --- | --- | --- | --- | --- | --- | --- | --- | --- | --- | --- | --- | --- |
|  | 12 | **Internal Signage & Tags** |  |  | 2016-11-27 | 2017-04-04 |  |  |  |  |  |  |  |  |
| PR-Z3-GE-GE-217-0010 |  | RFQ - Internal Signage & Tags |  | 5.6d | 2016-11-27 | 2016-12-04 | PROC-GE-GE-GE-0010 FS+90.4d | 187.8d | 0d |  | OK | 1.2.3.30 | PROC | PROC |
| PR-Z3-GE-GE-217-0020 |  | Material Submittal - Internal Signage & Tags |  | 8d | 2016-12-04 | 2016-12-13 | PR-Z3-GE-GE-217-0010 | 187.8d | 0d |  | OK | 1.2.3.30 | PROC | PROC |
| PR-Z3-GE-GE-217-0030 |  | Material Approval - Internal Signage & Tags |  | 11.2d | 2016-12-13 | 2016-12-26 | PR-Z3-GE-GE-217-0020 | 187.8d | 0d |  | OK | 1.2.3.30 | PROC | PROC |
| PR-Z3-GE-GE-217-0040 |  | Technical Evaluation - Internal Signage & Tags |  | 8d | 2016-12-26 | 2017-01-04 | PR-Z3-GE-GE-217-0030 | 187.8d | 0d |  | OK | 1.2.3.30 | PROC | PROC |
| PR-Z3-GE-GE-217-0050 |  | PO - Internal Signage & Tags |  | 11.2d | 2017-01-04 | 2017-01-17 | PR-Z3-GE-GE-217-0040 | 187.8d | 0d |  | OK | 1.2.3.30 | PROC | PROC |
| PR-Z3-GE-GE-217-0060 |  | NMR 601 - Internal Signage & Tags |  | 4.8d | 2017-01-17 | 2017-01-23 | PR-Z3-GE-GE-217-0050 | 187.8d | 0d |  | OK | 1.2.3.30 | PROC | PROC |
| PR-Z3-GE-GE-217-0070 |  | NMR 602 - Internal Signage & Tags |  | 4.8d | 2017-01-23 | 2017-01-29 | PR-Z3-GE-GE-217-0060 | 187.8d | 0d |  | OK | 1.2.3.30 | PROC | PROC |
| PR-Z3-GE-GE-217-0080 |  | Start of Material Delivery - Internal Signage & Tags | milestone | 0d | 2017-03-12 | 2017-03-12 | PR-Z3-GE-GE-217-0070 FS+36d | 187.8d | 0d |  | OK | 1.2.3.30 | PROC | PROC |
| PR-Z3-GE-GE-217-0090 |  | Complete Material Delivery - Internal Signage & Tags |  | 12d | 2017-03-12 | 2017-03-26 | PR-Z3-GE-GE-217-0080 | 249.8d | 0d | Internal Signage & Tags [1 ea] | OK | 1.2.3.30 | PROC | PROC |
| PR-Z3-GE-GE-217-0100 |  | NMR 603 - Internal Signage & Tags |  | 8d | 2017-03-26 | 2017-04-04 | PR-Z3-GE-GE-217-0090 | 249.8d | 167.6d |  | OK | 1.2.3.30 | PROC | PROC |
|  | 13 | **Paint (Epoxy Coating)** |  |  | 2016-11-08 | 2017-02-02 |  |  |  |  |  |  |  |  |
| PR-Z3-GE-GE-218-0010 |  | RFQ - Paint (Epoxy Coating) |  | 5.6d | 2016-11-08 | 2016-11-15 | PROC-GE-GE-GE-0010 FS+74.4d | 47.4d | 0d |  | OK | 1.2.3.30 | PROC | PROC |
| PR-Z3-GE-GE-218-0020 |  | Material Submittal - Paint (Epoxy Coating) |  | 8d | 2016-11-15 | 2016-11-24 | PR-Z3-GE-GE-218-0010 | 47.4d | 0d |  | OK | 1.2.3.30 | PROC | PROC |
| PR-Z3-GE-GE-218-0030 |  | Material Approval - Paint (Epoxy Coating) |  | 11.2d | 2016-11-24 | 2016-12-07 | PR-Z3-GE-GE-218-0020 | 47.4d | 0d |  | OK | 1.2.3.30 | PROC | PROC |
| PR-Z3-GE-GE-218-0040 |  | Technical Evaluation - Paint (Epoxy Coating) |  | 8d | 2016-12-07 | 2016-12-17 | PR-Z3-GE-GE-218-0030 | 47.4d | 0d |  | OK | 1.2.3.30 | PROC | PROC |
| PR-Z3-GE-GE-218-0050 |  | PO - Paint (Epoxy Coating) |  | 11.2d | 2016-12-17 | 2016-12-29 | PR-Z3-GE-GE-218-0040 | 47.4d | 0d |  | OK | 1.2.3.30 | PROC | PROC |
| PR-Z3-GE-GE-218-0060 |  | NMR 601 - Paint (Epoxy Coating) |  | 4.8d | 2016-12-29 | 2017-01-04 | PR-Z3-GE-GE-218-0050 | 47.4d | 0d |  | OK | 1.2.3.30 | PROC | PROC |
| PR-Z3-GE-GE-218-0070 |  | NMR 602 - Paint (Epoxy Coating) |  | 4.8d | 2017-01-04 | 2017-01-10 | PR-Z3-GE-GE-218-0060 | 47.4d | 0d |  | OK | 1.2.3.30 | PROC | PROC |
| PR-Z3-GE-GE-218-0080 |  | Start of Material Delivery - Paint (Epoxy Coating) | milestone | 0d | 2017-01-10 | 2017-01-10 | PR-Z3-GE-GE-218-0070 | 47.4d | 0d |  | OK | 1.2.3.30 | PROC | PROC |
| PR-Z3-GE-GE-218-0090 |  | Complete Material Delivery - Paint (Epoxy Coating) |  | 12d | 2017-01-10 | 2017-01-24 | PR-Z3-GE-GE-218-0080 | 301.8d | 0d | Paint - Epoxy Coating [492 Sqm] | OK | 1.2.3.30 | PROC | PROC |
| PR-Z3-GE-GE-218-0100 |  | NMR 603 - Paint (Epoxy Coating) |  | 8d | 2017-01-24 | 2017-02-02 | PR-Z3-GE-GE-218-0090 | 301.8d | 219.6d |  | OK | 1.2.3.30 | PROC | PROC |
|  | 14 | **Wooden Trellis & Canopy** |  |  | 2016-11-15 | 2017-03-25 |  |  |  |  |  |  |  |  |
| PR-Z3-GE-GE-220-0010 |  | RFQ - Wooden Trellis & Canopy |  | 5.6d | 2016-11-15 | 2016-11-21 | PROC-GE-GE-GE-0010 FS+80d | 214.6d | 0d |  | OK | 1.2.3.30 | PROC | PROC |
| PR-Z3-GE-GE-220-0020 |  | Material Submittal - Wooden Trellis & Canopy |  | 8d | 2016-11-21 | 2016-11-30 | PR-Z3-GE-GE-220-0010 | 214.6d | 0d |  | OK | 1.2.3.30 | PROC | PROC |
| PR-Z3-GE-GE-220-0030 |  | Material Approval - Wooden Trellis & Canopy |  | 11.2d | 2016-11-30 | 2016-12-13 | PR-Z3-GE-GE-220-0020 | 214.6d | 0d |  | OK | 1.2.3.30 | PROC | PROC |
| PR-Z3-GE-GE-220-0040 |  | Technical Evaluation - Wooden Trellis & Canopy |  | 8d | 2016-12-14 | 2016-12-22 | PR-Z3-GE-GE-220-0030 | 214.6d | 0d |  | OK | 1.2.3.30 | PROC | PROC |
| PR-Z3-GE-GE-220-0050 |  | PO - Wooden Trellis & Canopy |  | 11.2d | 2016-12-24 | 2017-01-05 | PR-Z3-GE-GE-220-0040 | 214.6d | 0d |  | OK | 1.2.3.30 | PROC | PROC |
| PR-Z3-GE-GE-220-0060 |  | NMR 601 - Wooden Trellis & Canopy |  | 4.8d | 2017-01-05 | 2017-01-10 | PR-Z3-GE-GE-220-0050 | 214.6d | 0d |  | OK | 1.2.3.30 | PROC | PROC |
| PR-Z3-GE-GE-220-0070 |  | NMR 602 - Wooden Trellis & Canopy |  | 4.8d | 2017-01-11 | 2017-01-16 | PR-Z3-GE-GE-220-0060 | 214.6d | 0d |  | OK | 1.2.3.30 | PROC | PROC |
| PR-Z3-GE-GE-220-0080 |  | Start of Material Delivery - Wooden Trellis & Canopy | milestone | 0d | 2017-03-01 | 2017-03-01 | PR-Z3-GE-GE-220-0070 FS+37.6d | 214.6d | 0d |  | OK | 1.2.3.30 | PROC | PROC |
| PR-Z3-GE-GE-220-0090 |  | Complete Material Delivery - Wooden Trellis & Canopy |  | 12d | 2017-03-01 | 2017-03-15 | PR-Z3-GE-GE-220-0080 | 258.6d | 0d | Wooden Trellis & Canopy [719.7 Sqm] | OK | 1.2.3.30 | PROC | PROC |
| PR-Z3-GE-GE-220-0100 |  | NMR 603 - Wooden Trellis & Canopy |  | 8d | 2017-03-15 | 2017-03-25 | PR-Z3-GE-GE-220-0090 | 258.6d | 176.4d |  | OK | 1.2.3.30 | PROC | PROC |

| ID | WBS | Activity | Type | Duration | Start | Finish | Predecessors | Total float | Free float | Resources | Wajid | RPI_P2 - BOQ ITEMS | RPI_P2 - PROCUREMENT | RPI_P2 - PHASE |
| --- | --- | --- | --- | --- | --- | --- | --- | --- | --- | --- | --- | --- | --- | --- |
|  | 15 | **Chain Link Fence & Gate** |  |  | 2016-11-13 | 2017-02-28 |  |  |  |  |  |  |  |  |
| PR-Z3-GE-GE-221-0010 |  | RFQ - Chain Link Fence & Gate |  | 5.6d | 2016-11-13 | 2016-11-19 | PROC-GE-GE-GE-0010 FS+78d | 204.8d | 0d |  | OK | 1.2.3.30 | PROC | PROC |
| PR-Z3-GE-GE-221-0020 |  | Material Submittal - Chain Link Fence & Gate |  | 8d | 2016-11-19 | 2016-11-28 | PR-Z3-GE-GE-221-0010 | 204.8d | 0d |  | OK | 1.2.3.30 | PROC | PROC |
| PR-Z3-GE-GE-221-0030 |  | Material Approval - Chain Link Fence & Gate |  | 11.2d | 2016-11-28 | 2016-12-11 | PR-Z3-GE-GE-221-0020 | 204.8d | 0d |  | OK | 1.2.3.30 | PROC | PROC |
| PR-Z3-GE-GE-221-0040 |  | Technical Evaluation - Chain Link Fence & Gate |  | 8d | 2016-12-12 | 2016-12-20 | PR-Z3-GE-GE-221-0030 | 204.8d | 0d |  | OK | 1.2.3.30 | PROC | PROC |
| PR-Z3-GE-GE-221-0050 |  | PO - Chain Link Fence & Gate |  | 11.2d | 2016-12-21 | 2017-01-03 | PR-Z3-GE-GE-221-0040 | 204.8d | 0d |  | OK | 1.2.3.30 | PROC | PROC |
| PR-Z3-GE-GE-221-0060 |  | NMR 601 - Chain Link Fence & Gate |  | 4.8d | 2017-01-03 | 2017-01-08 | PR-Z3-GE-GE-221-0050 | 204.8d | 0d |  | OK | 1.2.3.30 | PROC | PROC |
| PR-Z3-GE-GE-221-0070 |  | NMR 602 - Chain Link Fence & Gate |  | 4.8d | 2017-01-09 | 2017-01-14 | PR-Z3-GE-GE-221-0060 | 204.8d | 0d |  | OK | 1.2.3.30 | PROC | PROC |
| PR-Z3-GE-GE-221-0080 |  | Start of Material Delivery - Chain Link Fence & Gate | milestone | 0d | 2017-02-05 | 2017-02-05 | PR-Z3-GE-GE-221-0070 FS+18.4d | 204.8d | 0d |  | OK | 1.2.3.30 | PROC | PROC |
| PR-Z3-GE-GE-221-0090 |  | Complete Material Delivery - Chain Link Fence & Gate |  | 12d | 2017-02-05 | 2017-02-19 | PR-Z3-GE-GE-221-0080 | 279.8d | 0d | Chain Link Fence & Gate [2844.7 Lm] | OK | 1.2.3.30 | PROC | PROC |
| PR-Z3-GE-GE-221-0100 |  | NMR 603 - Chain Link Fence & Gate |  | 8d | 2017-02-19 | 2017-02-28 | PR-Z3-GE-GE-221-0090 | 279.8d | 197.6d |  | OK | 1.2.3.30 | PROC | PROC |
|  | 16 | **Pre-cast Concrete Fence (for Lift Stations)** |  |  | 2016-10-16 | 2017-02-19 |  |  |  |  |  |  |  |  |
| PR-Z3-GE-GE-222-0010 |  | RFQ - Pre-cast Concrete Fence (for Lift Stations) |  | 5.6d | 2016-10-16 | 2016-10-23 | PROC-GE-GE-GE-0010 FS+54.4d | 166d | 0d |  | OK | 1.2.3.30 | PROC | PROC |
| PR-Z3-GE-GE-222-0020 |  | Material Submittal - Pre-cast Concrete Fence (for Lift Stations) |  | 8d | 2016-10-23 | 2016-11-01 | PR-Z3-GE-GE-222-0010 | 166d | 0d |  | OK | 1.2.3.30 | PROC | PROC |
| PR-Z3-GE-GE-222-0030 |  | Material Approval - Pre-cast Concrete Fence (for Lift Stations) |  | 11.2d | 2016-11-01 | 2016-11-14 | PR-Z3-GE-GE-222-0020 | 166d | 0d |  | OK | 1.2.3.30 | PROC | PROC |
| PR-Z3-GE-GE-222-0040 |  | Technical Evaluation - Pre-cast Concrete Fence (for Lift Stations) |  | 8d | 2016-11-14 | 2016-11-23 | PR-Z3-GE-GE-222-0030 | 166d | 0d |  | OK | 1.2.3.30 | PROC | PROC |
| PR-Z3-GE-GE-222-0050 |  | PO - Pre-cast Concrete Fence (for Lift Stations) |  | 11.2d | 2016-11-23 | 2016-12-06 | PR-Z3-GE-GE-222-0040 | 166d | 0d |  | OK | 1.2.3.30 | PROC | PROC |
| PR-Z3-GE-GE-222-0060 |  | NMR 601 - Pre-cast Concrete Fence (for Lift Stations) |  | 4.8d | 2016-12-06 | 2016-12-12 | PR-Z3-GE-GE-222-0050 | 166d | 0d |  | OK | 1.2.3.30 | PROC | PROC |
| PR-Z3-GE-GE-222-0070 |  | NMR 602 - Pre-cast Concrete Fence (for Lift Stations) |  | 4.8d | 2016-12-12 | 2016-12-18 | PR-Z3-GE-GE-222-0060 | 166d | 0d |  | OK | 1.2.3.30 | PROC | PROC |
| PR-Z3-GE-GE-222-0080 |  | Start of Material Delivery - Pre-cast Concrete Fence (for Lift Stations) | milestone | 0d | 2017-01-26 | 2017-01-26 | PR-Z3-GE-GE-222-0070 FS+34.4d | 166d | 0d |  | OK | 1.2.3.30 | PROC | PROC |
| PR-Z3-GE-GE-222-0090 |  | Complete Material Delivery - Pre-cast Concrete Fence (for Lift Stations) |  | 12d | 2017-01-26 | 2017-02-09 | PR-Z3-GE-GE-222-0080 | 287.4d | 0d | Pre-cast Concrete Fence (for Lift Stations) [254.6 Lm] | OK | 1.2.3.30 | PROC | PROC |
| PR-Z3-GE-GE-222-0100 |  | NMR 603 - Pre-cast Concrete Fence (for Lift Stations) |  | 8d | 2017-02-09 | 2017-02-19 | PR-Z3-GE-GE-222-0090 | 287.4d | 205.2d |  | OK | 1.2.3.30 | PROC | PROC |
|  | 17 | **Steel Gate for Lift Stations** |  |  | 2016-09-19 | 2017-02-22 |  |  |  |  |  |  |  |  |
| PR-Z3-GE-GE-223-0010 |  | RFQ - Steel Gate for Lift Stations |  | 5.6d | 2016-09-19 | 2016-09-25 | PROC-GE-GE-GE-0010 FS+31.2d | 177.2d | 0d |  | OK | 1.2.3.30 | PROC | PROC |
| PR-Z3-GE-GE-223-0020 |  | Material Submittal - Steel Gate for Lift Stations |  | 8d | 2016-09-26 | 2016-10-04 | PR-Z3-GE-GE-223-0010 | 177.2d | 0d |  | OK | 1.2.3.30 | PROC | PROC |
| PR-Z3-GE-GE-223-0030 |  | Material Approval - Steel Gate for Lift Stations |  | 11.2d | 2016-10-05 | 2016-10-18 | PR-Z3-GE-GE-223-0020 | 177.2d | 0d |  | OK | 1.2.3.30 | PROC | PROC |
| PR-Z3-GE-GE-223-0040 |  | Technical Evaluation - Steel Gate for Lift Stations |  | 8d | 2016-10-18 | 2016-10-27 | PR-Z3-GE-GE-223-0030 | 177.2d | 0d |  | OK | 1.2.3.30 | PROC | PROC |
| PR-Z3-GE-GE-223-0050 |  | PO - Steel Gate for Lift Stations |  | 11.2d | 2016-10-27 | 2016-11-09 | PR-Z3-GE-GE-223-0040 | 177.2d | 0d |  | OK | 1.2.3.30 | PROC | PROC |
| PR-Z3-GE-GE-223-0060 |  | NMR 601 - Steel Gate for Lift Stations |  | 4.8d | 2016-11-09 | 2016-11-15 | PR-Z3-GE-GE-223-0050 | 177.2d | 0d |  | OK | 1.2.3.30 | PROC | PROC |
| PR-Z3-GE-GE-223-0070 |  | NMR 602 - Steel Gate for Lift Stations |  | 4.8d | 2016-11-15 | 2016-11-20 | PR-Z3-GE-GE-223-0060 | 177.2d | 0d |  | OK | 1.2.3.30 | PROC | PROC |
| PR-Z3-GE-GE-223-0080 |  | Start of Material Delivery - Steel Gate for Lift Stations | milestone | 0d | 2017-01-30 | 2017-01-30 | PR-Z3-GE-GE-223-0070 FS+60.8d | 177.2d | 0d |  | OK | 1.2.3.30 | PROC | PROC |
| PR-Z3-GE-GE-223-0090 |  | Complete Material Delivery - Steel Gate for Lift Stations |  | 12d | 2017-01-30 | 2017-02-13 | PR-Z3-GE-GE-223-0080 | 284.2d | 0d | Steel Gate for Lift Stations [3 ea] | OK | 1.2.3.30 | PROC | PROC |
| PR-Z3-GE-GE-223-0100 |  | NMR 603 - Steel Gate for Lift Stations |  | 8d | 2017-02-13 | 2017-02-22 | PR-Z3-GE-GE-223-0090 | 284.2d | 202d |  | OK | 1.2.3.30 | PROC | PROC |

| ID | WBS | Activity | Type | Duration | Start | Finish | Predecessors | Total float | Free float | Resources | Wajid | RPI_P2 - BOQ ITEMS | RPI_P2 - PROCUREMENT | RPI_P2 - PHASE |
| --- | --- | --- | --- | --- | --- | --- | --- | --- | --- | --- | --- | --- | --- | --- |
|  | 18 | **Water Proofing & Roofing System** |  |  | 2016-09-07 | 2016-12-28 |  |  |  |  |  |  |  |  |
| PR-Z3-GE-GE-224-0010 |  | RFQ - Water Proofing & Roofing System |  | 5.6d | 2016-09-07 | 2016-09-18 | PROC-GE-GE-GE-0010 FS+25d | 56d | 0d |  | OK | 1.2.3.30 | PROC | PROC |
| PR-Z3-GE-GE-224-0020 |  | Material Submittal - Water Proofing & Roofing System |  | 8d | 2016-09-18 | 2016-09-27 | PR-Z3-GE-GE-224-0010 | 56d | 0d |  | OK | 1.2.3.30 | PROC | PROC |
| PR-Z3-GE-GE-224-0030 |  | Material Approval - Water Proofing & Roofing System |  | 11.2d | 2016-09-27 | 2016-10-10 | PR-Z3-GE-GE-224-0020 | 56d | 0d |  | OK | 1.2.3.30 | PROC | PROC |
| PR-Z3-GE-GE-224-0040 |  | Technical Evaluation - Water Proofing & Roofing System |  | 8d | 2016-10-11 | 2016-10-19 | PR-Z3-GE-GE-224-0030 | 56d | 0d |  | OK | 1.2.3.30 | PROC | PROC |
| PR-Z3-GE-GE-224-0050 |  | PO - Water Proofing & Roofing System |  | 11.2d | 2016-10-20 | 2016-11-02 | PR-Z3-GE-GE-224-0040 | 56d | 0d |  | OK | 1.2.3.30 | PROC | PROC |
| PR-Z3-GE-GE-224-0060 |  | NMR 601 - Water Proofing & Roofing System |  | 4.8d | 2016-11-02 | 2016-11-07 | PR-Z3-GE-GE-224-0050 | 56d | 0d |  | OK | 1.2.3.30 | PROC | PROC |
| PR-Z3-GE-GE-224-0070 |  | NMR 602 - Water Proofing & Roofing System |  | 4.8d | 2016-11-08 | 2016-11-13 | PR-Z3-GE-GE-224-0060 | 56d | 0d |  | OK | 1.2.3.30 | PROC | PROC |
| PR-Z3-GE-GE-224-0080 |  | Start of Material Delivery - Water Proofing & Roofing System | milestone | 0d | 2016-12-06 | 2016-12-06 | PR-Z3-GE-GE-224-0070 FS+19.2d | 56d | 0d |  | OK | 1.2.3.30 | PROC | PROC |
| PR-Z3-GE-GE-224-0090 |  | Complete Material Delivery - Water Proofing & Roofing System |  | 12d | 2016-12-06 | 2016-12-19 | PR-Z3-GE-GE-224-0080 | 332d | 0d | Water Proofing & Roofing System [723.2 Sqm] | OK | 1.2.3.30 | PROC | PROC |
| PR-Z3-GE-GE-224-0100 |  | NMR 603 - Water Proofing & Roofing System |  | 8d | 2016-12-20 | 2016-12-28 | PR-Z3-GE-GE-224-0090 | 332d | 249.8d |  | OK | 1.2.3.30 | PROC | PROC |
|  | 19 | **FRP Ladders, Covers & Gratting** |  |  | 2016-09-18 | 2017-01-24 |  |  |  |  |  |  |  |  |
| PR-Z3-GE-GE-225-0010 |  | RFQ - FRP Ladders, Covers & Gratting |  | 5.6d | 2016-09-18 | 2016-09-24 | PROC-GE-GE-GE-0010 FS+30d | 89.4d | 0d |  | OK | 1.2.3.30 | PROC | PROC |
| PR-Z3-GE-GE-225-0020 |  | Material Submittal - FRP Ladders, Covers & Gratting |  | 8d | 2016-09-24 | 2016-10-03 | PR-Z3-GE-GE-225-0010 | 89.4d | 0d |  | OK | 1.2.3.30 | PROC | PROC |
| PR-Z3-GE-GE-225-0030 |  | Material Approval - FRP Ladders, Covers & Gratting |  | 11.2d | 2016-10-03 | 2016-10-16 | PR-Z3-GE-GE-225-0020 | 89.4d | 0d |  | OK | 1.2.3.30 | PROC | PROC |
| PR-Z3-GE-GE-225-0040 |  | Technical Evaluation - FRP Ladders, Covers & Gratting |  | 8d | 2016-10-17 | 2016-10-25 | PR-Z3-GE-GE-225-0030 | 89.4d | 0d |  | OK | 1.2.3.30 | PROC | PROC |
| PR-Z3-GE-GE-225-0050 |  | PO - FRP Ladders, Covers & Gratting |  | 11.2d | 2016-10-26 | 2016-11-08 | PR-Z3-GE-GE-225-0040 | 89.4d | 0d |  | OK | 1.2.3.30 | PROC | PROC |
| PR-Z3-GE-GE-225-0060 |  | NMR 601 - FRP Ladders, Covers & Gratting |  | 4.8d | 2016-11-08 | 2016-11-13 | PR-Z3-GE-GE-225-0050 | 89.4d | 0d |  | OK | 1.2.3.30 | PROC | PROC |
| PR-Z3-GE-GE-225-0070 |  | NMR 602 - FRP Ladders, Covers & Gratting |  | 4.8d | 2016-11-14 | 2016-11-19 | PR-Z3-GE-GE-225-0060 | 89.4d | 0d |  | OK | 1.2.3.30 | PROC | PROC |
| PR-Z3-GE-GE-225-0080 |  | Start of Material Delivery - FRP Ladders, Covers & Gratting | milestone | 0d | 2016-12-12 | 2016-12-12 | PR-Z3-GE-GE-225-0070 FS+19.2d | 89.4d | 0d |  | OK | 1.2.3.30 | PROC | PROC |
| PR-Z3-GE-GE-225-0090 |  | Complete Material Delivery - FRP Ladders, Covers & Gratting |  | 30d | 2016-12-12 | 2017-01-15 | PR-Z3-GE-GE-225-0080 | 309d | 0d | FRP - Ladders, Covers & Gratting [22 ea] | OK | 1.2.3.30 | PROC | PROC |
| PR-Z3-GE-GE-225-0100 |  | NMR 603 - FRP Ladders, Covers & Gratting |  | 8d | 2017-01-16 | 2017-01-24 | PR-Z3-GE-GE-225-0090 | 309d | 226.8d |  | OK | 1.2.3.30 | PROC | PROC |
|  | 20 | **Lifting Hoist for Lift Stations** |  |  | 2016-09-18 | 2017-02-20 |  |  |  |  |  |  |  |  |
| PR-Z3-GE-GE-226-0010 |  | RFQ - Lifting Hoist for Lift Stations |  | 5.6d | 2016-09-18 | 2016-09-25 | PROC-GE-GE-GE-0010 FS+30.4d | 100.4d | 0d |  | OK | 1.2.3.30 | PROC | PROC |
| PR-Z3-GE-GE-226-0020 |  | Material Submittal - Lifting Hoist for Lift Stations |  | 8d | 2016-09-25 | 2016-10-04 | PR-Z3-GE-GE-226-0010 | 100.4d | 0d |  | OK | 1.2.3.30 | PROC | PROC |
| PR-Z3-GE-GE-226-0030 |  | Material Approval - Lifting Hoist for Lift Stations |  | 11.2d | 2016-10-04 | 2016-10-17 | PR-Z3-GE-GE-226-0020 | 100.4d | 0d |  | OK | 1.2.3.30 | PROC | PROC |
| PR-Z3-GE-GE-226-0040 |  | Technical Evaluation - Lifting Hoist for Lift Stations |  | 8d | 2016-10-17 | 2016-10-26 | PR-Z3-GE-GE-226-0030 | 100.4d | 0d |  | OK | 1.2.3.30 | PROC | PROC |
| PR-Z3-GE-GE-226-0050 |  | PO - Lifting Hoist for Lift Stations |  | 11.2d | 2016-10-26 | 2016-11-08 | PR-Z3-GE-GE-226-0040 | 100.4d | 0d |  | OK | 1.2.3.30 | PROC | PROC |
| PR-Z3-GE-GE-226-0060 |  | NMR 601 - Lifting Hoist for Lift Stations |  | 4.8d | 2016-11-08 | 2016-11-14 | PR-Z3-GE-GE-226-0050 | 100.4d | 0d |  | OK | 1.2.3.30 | PROC | PROC |
| PR-Z3-GE-GE-226-0070 |  | NMR 602 - Lifting Hoist for Lift Stations |  | 4.8d | 2016-11-14 | 2016-11-20 | PR-Z3-GE-GE-226-0060 | 100.4d | 0d |  | OK | 1.2.3.30 | PROC | PROC |
| PR-Z3-GE-GE-226-0080 |  | Start of Material Delivery - Lifting Hoist for Lift Stations | milestone | 0d | 2017-01-28 | 2017-01-28 | PR-Z3-GE-GE-226-0070 FS+59.2d | 100.4d | 0d |  | OK | 1.2.3.30 | PROC | PROC |
| PR-Z3-GE-GE-226-0090 |  | Complete Material Delivery - Lifting Hoist for Lift Stations |  | 12d | 2017-01-28 | 2017-02-11 | PR-Z3-GE-GE-226-0080 | 286.6d | 0d | Lifting Hoist for Lift Stations [3 ea] | OK | 1.2.3.30 | PROC | PROC |
| PR-Z3-GE-GE-226-0100 |  | NMR 603 - Lifting Hoist for Lift Stations |  | 8d | 2017-02-11 | 2017-02-20 | PR-Z3-GE-GE-226-0090 | 286.6d | 204.4d |  | OK | 1.2.3.30 | PROC | PROC |

| ID | WBS | Activity | Type | Duration | Start | Finish | Predecessors | Total float | Free float | Resources | Wajid | RPI_P2 - BOQ ITEMS | RPI_P2 - PROCUREMENT | RPI_P2 - PHASE |
| --- | --- | --- | --- | --- | --- | --- | --- | --- | --- | --- | --- | --- | --- | --- |
|  | 21 | **Door Hardware & Accessories** |  |  | 2016-09-06 | 2017-03-07 |  |  |  |  |  |  |  |  |
| PR-Z3-GE-GE-227-0010 |  | RFQ - Door Hardware & Accessories |  | 5.6d | 2016-09-06 | 2016-09-17 | PROC-GE-GE-GE-0010 FS+24d | 32.2d | 0d |  | OK | 1.2.3.30 | PROC | PROC |
| PR-Z3-GE-GE-227-0020 |  | Material Submittal - Door Hardware & Accessories |  | 8d | 2016-09-17 | 2016-09-26 | PR-Z3-GE-GE-227-0010 | 32.2d | 0d |  | OK | 1.2.3.30 | PROC | PROC |
| PR-Z3-GE-GE-227-0030 |  | Material Approval - Door Hardware & Accessories |  | 11.2d | 2016-09-26 | 2016-10-09 | PR-Z3-GE-GE-227-0020 | 32.2d | 0d |  | OK | 1.2.3.30 | PROC | PROC |
| PR-Z3-GE-GE-227-0040 |  | Technical Evaluation - Door Hardware & Accessories |  | 8d | 2016-10-10 | 2016-10-18 | PR-Z3-GE-GE-227-0030 | 32.2d | 0d |  | OK | 1.2.3.30 | PROC | PROC |
| PR-Z3-GE-GE-227-0050 |  | PO - Door Hardware & Accessories |  | 11.2d | 2016-10-19 | 2016-11-01 | PR-Z3-GE-GE-227-0040 | 32.2d | 0d |  | OK | 1.2.3.30 | PROC | PROC |
| PR-Z3-GE-GE-227-0060 |  | NMR 601 - Door Hardware & Accessories |  | 4.8d | 2016-11-01 | 2016-11-06 | PR-Z3-GE-GE-227-0050 | 32.2d | 0d |  | OK | 1.2.3.30 | PROC | PROC |
| PR-Z3-GE-GE-227-0070 |  | NMR 602 - Door Hardware & Accessories |  | 4.8d | 2016-11-07 | 2016-11-12 | PR-Z3-GE-GE-227-0060 | 32.2d | 0d |  | OK | 1.2.3.30 | PROC | PROC |
| PR-Z3-GE-GE-227-0080 |  | Start of Material Delivery - Door Hardware & Accessories | milestone | 0d | 2017-02-16 | 2017-02-16 | PR-Z3-GE-GE-227-0070 FS+82.4d | 32.2d | 0d |  | OK | 1.2.3.30 | PROC | PROC |
| PR-Z3-GE-GE-227-0090 |  | Complete Material Delivery - Door Hardware & Accessories |  | 12d | 2017-02-16 | 2017-03-02 | PR-Z3-GE-GE-227-0080 | 273d | 0d | Door Hardware & Accessories [1 LS] | OK | 1.2.3.30 | PROC | PROC |
| PR-Z3-GE-GE-227-0100 |  | NMR 603 - Door Hardware & Accessories |  | 4.8d | 2017-03-02 | 2017-03-07 | PR-Z3-GE-GE-227-0090 | 273d | 190.8d |  | OK | 1.2.3.30 | PROC | PROC |
|  | 22 | **Sanitary Plumbing Fixtures & Toilet Accessories** |  |  | 2016-09-18 | 2017-02-20 |  |  |  |  |  |  |  |  |
| PR-Z3-GE-GE-228-0010 |  | RFQ - Sanitary Plumbing Fixtures & Toilet Accessories |  | 5.6d | 2016-09-18 | 2016-09-25 | PROC-GE-GE-GE-0010 FS+30.4d | 210.6d | 0d |  | OK | 1.2.3.30 | PROC | PROC |
| PR-Z3-GE-GE-228-0020 |  | Material Submittal - Sanitary Plumbing Fixtures & Toilet Accessories |  | 8d | 2016-09-25 | 2016-10-04 | PR-Z3-GE-GE-228-0010 | 210.6d | 0d |  | OK | 1.2.3.30 | PROC | PROC |
| PR-Z3-GE-GE-228-0030 |  | Material Approval - Sanitary Plumbing Fixtures & Toilet Accessories |  | 11.2d | 2016-10-04 | 2016-10-17 | PR-Z3-GE-GE-228-0020 | 210.6d | 0d |  | OK | 1.2.3.30 | PROC | PROC |
| PR-Z3-GE-GE-228-0040 |  | Technical Evaluation - Sanitary Plumbing Fixtures & Toilet Accessories |  | 8d | 2016-10-17 | 2016-10-26 | PR-Z3-GE-GE-228-0030 | 210.6d | 0d |  | OK | 1.2.3.30 | PROC | PROC |
| PR-Z3-GE-GE-228-0050 |  | PO - Sanitary Plumbing Fixtures & Toilet Accessories |  | 11.2d | 2016-10-26 | 2016-11-08 | PR-Z3-GE-GE-228-0040 | 210.6d | 0d |  | OK | 1.2.3.30 | PROC | PROC |
| PR-Z3-GE-GE-228-0060 |  | NMR 601 - Sanitary Plumbing Fixtures & Toilet Accessories |  | 4.8d | 2016-11-08 | 2016-11-14 | PR-Z3-GE-GE-228-0050 | 210.6d | 0d |  | OK | 1.2.3.30 | PROC | PROC |
| PR-Z3-GE-GE-228-0070 |  | NMR 602 - Sanitary Plumbing Fixtures & Toilet Accessories |  | 4.8d | 2016-11-14 | 2016-11-20 | PR-Z3-GE-GE-228-0060 | 210.6d | 0d |  | OK | 1.2.3.30 | PROC | PROC |
| PR-Z3-GE-GE-228-0080 |  | Start of Material Delivery - Sanitary Plumbing Fixtures & Toilet Accessories | milestone | 0d | 2017-01-28 | 2017-01-28 | PR-Z3-GE-GE-228-0070 FS+59.2d | 210.6d | 0d |  | OK | 1.2.3.30 | PROC | PROC |
| PR-Z3-GE-GE-228-0090 |  | Complete Material Delivery - Sanitary Plumbing Fixtures & Toilet Accessories |  | 12d | 2017-01-28 | 2017-02-11 | PR-Z3-GE-GE-228-0080 | 286.6d | 0d | Sanitary Plumbing Fixtures & Toilet Accessories [168 ea] | OK | 1.2.3.30 | PROC | PROC |
| PR-Z3-GE-GE-228-0100 |  | NMR 603 - Sanitary Plumbing Fixtures & Toilet Accessories |  | 8d | 2017-02-11 | 2017-02-20 | PR-Z3-GE-GE-228-0090 | 286.6d | 204.4d |  | OK | 1.2.3.30 | PROC | PROC |
|  | 23 | **Snack Bar Counter & Cabinet** |  |  | 2016-10-19 | 2017-03-12 |  |  |  |  |  |  |  |  |
| PR-Z3-GE-GE-229-0010 |  | RFQ - Snack Bar Counter & Cabinet |  | 5.6d | 2016-10-19 | 2016-10-25 | PROC-GE-GE-GE-0010 FS+56.8d | 241.8d | 0d |  | OK | 1.2.3.30 | PROC | PROC |
| PR-Z3-GE-GE-229-0020 |  | Material Submittal - Snack Bar Counter & Cabinet |  | 8d | 2016-10-25 | 2016-11-03 | PR-Z3-GE-GE-229-0010 | 241.8d | 0d |  | OK | 1.2.3.30 | PROC | PROC |
| PR-Z3-GE-GE-229-0030 |  | Material Approval - Snack Bar Counter & Cabinet |  | 11.2d | 2016-11-03 | 2016-11-16 | PR-Z3-GE-GE-229-0020 | 241.8d | 0d |  | OK | 1.2.3.30 | PROC | PROC |
| PR-Z3-GE-GE-229-0040 |  | Technical Evaluation - Snack Bar Counter & Cabinet |  | 8d | 2016-11-16 | 2016-11-26 | PR-Z3-GE-GE-229-0030 | 241.8d | 0d |  | OK | 1.2.3.30 | PROC | PROC |
| PR-Z3-GE-GE-229-0050 |  | PO - Snack Bar Counter & Cabinet |  | 11.2d | 2016-11-26 | 2016-12-08 | PR-Z3-GE-GE-229-0040 | 241.8d | 0d |  | OK | 1.2.3.30 | PROC | PROC |
| PR-Z3-GE-GE-229-0060 |  | NMR 601 - Snack Bar Counter & Cabinet |  | 4.8d | 2016-12-10 | 2016-12-14 | PR-Z3-GE-GE-229-0050 | 241.8d | 0d |  | OK | 1.2.3.30 | PROC | PROC |
| PR-Z3-GE-GE-229-0070 |  | NMR 602 - Snack Bar Counter & Cabinet |  | 4.8d | 2016-12-14 | 2016-12-20 | PR-Z3-GE-GE-229-0060 | 241.8d | 0d |  | OK | 1.2.3.30 | PROC | PROC |
| PR-Z3-GE-GE-229-0080 |  | Start of Material Delivery - Snack Bar Counter & Cabinet | milestone | 0d | 2017-02-16 | 2017-02-16 | PR-Z3-GE-GE-229-0070 FS+49.6d | 241.8d | 0d |  | OK | 1.2.3.30 | PROC | PROC |
| PR-Z3-GE-GE-229-0090 |  | Complete Material Delivery - Snack Bar Counter & Cabinet |  | 12d | 2017-02-16 | 2017-03-02 | PR-Z3-GE-GE-229-0080 | 269.8d | 0d | Snack Bar Counter & Cabinet [4 ea] | OK | 1.2.3.30 | PROC | PROC |
| PR-Z3-GE-GE-229-0100 |  | NMR 603 - Snack Bar Counter & Cabinet |  | 8d | 2017-03-02 | 2017-03-12 | PR-Z3-GE-GE-229-0090 | 269.8d | 187.6d |  | OK | 1.2.3.30 | PROC | PROC |

| ID | WBS | Activity | Type | Duration | Start | Finish | Predecessors | Total float | Free float | Resources | Wajid | RPI_P2 - BOQ ITEMS | RPI_P2 - PROCUREMENT | RPI_P2 - PHASE |
| --- | --- | --- | --- | --- | --- | --- | --- | --- | --- | --- | --- | --- | --- | --- |
|  | 24 | **Aluminum Windows** |  |  | 2016-10-19 | 2017-03-12 |  |  |  |  |  |  |  |  |
| PR-Z3-GE-GE-230-0010 |  | RFQ - Aluminum Windows |  | 5.6d | 2016-10-19 | 2016-10-25 | PROC-GE-GE-GE-0010 FS+56.8d | 50.6d | 0d |  | OK | 1.2.3.30 | PROC | PROC |
| PR-Z3-GE-GE-230-0020 |  | Material Submittal - Aluminum Windows |  | 8d | 2016-10-25 | 2016-11-03 | PR-Z3-GE-GE-230-0010 | 50.6d | 0d |  | OK | 1.2.3.30 | PROC | PROC |
| PR-Z3-GE-GE-230-0030 |  | Material Approval - Aluminum Windows |  | 11.2d | 2016-11-03 | 2016-11-16 | PR-Z3-GE-GE-230-0020 | 50.6d | 0d |  | OK | 1.2.3.30 | PROC | PROC |
| PR-Z3-GE-GE-230-0040 |  | Technical Evaluation - Aluminum Windows |  | 8d | 2016-11-16 | 2016-11-26 | PR-Z3-GE-GE-230-0030 | 50.6d | 0d |  | OK | 1.2.3.30 | PROC | PROC |
| PR-Z3-GE-GE-230-0050 |  | PO - Aluminum Windows |  | 11.2d | 2016-11-26 | 2016-12-08 | PR-Z3-GE-GE-230-0040 | 50.6d | 0d |  | OK | 1.2.3.30 | PROC | PROC |
| PR-Z3-GE-GE-230-0060 |  | NMR 601 - Aluminum Windows |  | 4.8d | 2016-12-10 | 2016-12-14 | PR-Z3-GE-GE-230-0050 | 50.6d | 0d |  | OK | 1.2.3.30 | PROC | PROC |
| PR-Z3-GE-GE-230-0070 |  | NMR 602 - Aluminum Windows |  | 4.8d | 2016-12-14 | 2016-12-20 | PR-Z3-GE-GE-230-0060 | 50.6d | 0d |  | OK | 1.2.3.30 | PROC | PROC |
| PR-Z3-GE-GE-230-0080 |  | Start of Material Delivery - Aluminum Windows | milestone | 0d | 2017-02-16 | 2017-02-16 | PR-Z3-GE-GE-230-0070 FS+49.6d | 50.6d | 0d |  | OK | 1.2.3.30 | PROC | PROC |
| PR-Z3-GE-GE-230-0090 |  | Complete Material Delivery - Aluminum Windows |  | 12d | 2017-02-16 | 2017-03-02 | PR-Z3-GE-GE-230-0080 | 269.8d | 0d | Aluminum Windows [4 ea] | OK | 1.2.3.30 | PROC | PROC |
| PR-Z3-GE-GE-230-0100 |  | NMR 603 - Aluminum Windows |  | 8d | 2017-03-02 | 2017-03-12 | PR-Z3-GE-GE-230-0090 | 269.8d | 187.6d |  | OK | 1.2.3.30 | PROC | PROC |
|  | 25 | **Glass Blocks (for Toilets)** |  |  | 2016-10-23 | 2017-03-18 |  |  |  |  |  |  |  |  |
| PR-Z3-GE-GE-231-0010 |  | RFQ - Glass Blocks (for Toilets) |  | 5.6d | 2016-10-23 | 2016-10-29 | PROC-GE-GE-GE-0010 FS+60d | 188.2d | 0d |  | OK | 1.2.3.30 | PROC | PROC |
| PR-Z3-GE-GE-231-0020 |  | Material Submittal - Glass Blocks (for Toilets) |  | 8d | 2016-10-29 | 2016-11-07 | PR-Z3-GE-GE-231-0010 | 188.2d | 0d |  | OK | 1.2.3.30 | PROC | PROC |
| PR-Z3-GE-GE-231-0030 |  | Material Approval - Glass Blocks (for Toilets) |  | 11.2d | 2016-11-07 | 2016-11-20 | PR-Z3-GE-GE-231-0020 | 188.2d | 0d |  | OK | 1.2.3.30 | PROC | PROC |
| PR-Z3-GE-GE-231-0040 |  | Technical Evaluation - Glass Blocks (for Toilets) |  | 8d | 2016-11-21 | 2016-11-29 | PR-Z3-GE-GE-231-0030 | 188.2d | 0d |  | OK | 1.2.3.30 | PROC | PROC |
| PR-Z3-GE-GE-231-0050 |  | PO - Glass Blocks (for Toilets) |  | 11.2d | 2016-11-30 | 2016-12-13 | PR-Z3-GE-GE-231-0040 | 188.2d | 0d |  | OK | 1.2.3.30 | PROC | PROC |
| PR-Z3-GE-GE-231-0060 |  | NMR 601 - Glass Blocks (for Toilets) |  | 4.8d | 2016-12-13 | 2016-12-18 | PR-Z3-GE-GE-231-0050 | 188.2d | 0d |  | OK | 1.2.3.30 | PROC | PROC |
| PR-Z3-GE-GE-231-0070 |  | NMR 602 - Glass Blocks (for Toilets) |  | 4.8d | 2016-12-19 | 2016-12-24 | PR-Z3-GE-GE-231-0060 | 188.2d | 0d |  | OK | 1.2.3.30 | PROC | PROC |
| PR-Z3-GE-GE-231-0080 |  | Start of Material Delivery - Glass Blocks (for Toilets) | milestone | 0d | 2017-02-22 | 2017-02-22 | PR-Z3-GE-GE-231-0070 FS+52d | 188.2d | 0d |  | OK | 1.2.3.30 | PROC | PROC |
| PR-Z3-GE-GE-231-0090 |  | Complete Material Delivery - Glass Blocks (for Toilets) |  | 12d | 2017-02-22 | 2017-03-08 | PR-Z3-GE-GE-231-0080 | 264.2d | 0d | Glass Blocks (for Toilets) [16.79 Sqm] | OK | 1.2.3.30 | PROC | PROC |
| PR-Z3-GE-GE-231-0100 |  | NMR 603 - Glass Blocks (for Toilets) |  | 8d | 2017-03-08 | 2017-03-18 | PR-Z3-GE-GE-231-0090 | 264.2d | 182d |  | OK | 1.2.3.30 | PROC | PROC |
|  | 26 | **Gypum Board & Accessories (Toilets & Snack Bars)** |  |  | 2016-09-25 | 2017-04-30 |  |  |  |  |  |  |  |  |
| PR-Z3-GE-GE-232-0010 |  | RFQ - Gypum Board & Accessories (Toilets & Snack Bars) |  | 5.6d | 2016-09-25 | 2016-10-01 | PROC-GE-GE-GE-0010 FS+36d | 49d | 0d |  | OK | 1.2.3.30 | PROC | PROC |
| PR-Z3-GE-GE-232-0020 |  | Material Submittal - Gypum Board & Accessories (Toilets & Snack Bars) |  | 8d | 2016-10-01 | 2016-10-10 | PR-Z3-GE-GE-232-0010 | 49d | 0d |  | OK | 1.2.3.30 | PROC | PROC |
| PR-Z3-GE-GE-232-0030 |  | Material Approval - Gypum Board & Accessories (Toilets & Snack Bars) |  | 11.2d | 2016-10-10 | 2016-10-23 | PR-Z3-GE-GE-232-0020 | 49d | 0d |  | OK | 1.2.3.30 | PROC | PROC |
| PR-Z3-GE-GE-232-0040 |  | Technical Evaluation - Gypum Board & Accessories (Toilets & Snack Bars) |  | 8d | 2016-10-24 | 2016-11-01 | PR-Z3-GE-GE-232-0030 | 49d | 0d |  | OK | 1.2.3.30 | PROC | PROC |
| PR-Z3-GE-GE-232-0050 |  | PO - Gypum Board & Accessories (Toilets & Snack Bars) |  | 21d | 2016-11-02 | 2016-11-26 | PR-Z3-GE-GE-232-0040 | 49d | 0d |  | OK | 1.2.3.30 | PROC | PROC |
| PR-Z3-GE-GE-232-0060 |  | NMR 601 - Gypum Board & Accessories (Toilets & Snack Bars) |  | 12d | 2016-11-27 | 2016-12-10 | PR-Z3-GE-GE-232-0050 | 49d | 0d |  | OK | 1.2.3.30 | PROC | PROC |
| PR-Z3-GE-GE-232-0070 |  | NMR 602 - Gypum Board & Accessories (Toilets & Snack Bars) |  | 12d | 2016-12-11 | 2016-12-24 | PR-Z3-GE-GE-232-0060 | 49d | 0d |  | OK | 1.2.3.30 | PROC | PROC |
| PR-Z3-GE-GE-232-0080 |  | Start of Material Delivery - Gypum Board & Accessories (Toilets & Snack Bars) | milestone | 0d | 2017-04-09 | 2017-04-09 | PR-Z3-GE-GE-232-0070 FS+90d | 49d | 0d |  | OK | 1.2.3.30 | PROC | PROC |
| PR-Z3-GE-GE-232-0090 |  | Complete Material Delivery - Gypum Board & Accessories (Toilets & Snack Bars) |  | 12d | 2017-04-09 | 2017-04-22 | PR-Z3-GE-GE-232-0080 | 227d | 0d | Gypum Board & Accessories (Toilets & Snack Bars) [809 Sqm] | OK | 1.2.3.30 | PROC | PROC |
| PR-Z3-GE-GE-232-0100 |  | NMR 603 - Gypum Board & Accessories (Toilets & Snack Bars) |  | 7d | 2017-04-23 | 2017-04-30 | PR-Z3-GE-GE-232-0090 | 227d | 144.8d |  | OK | 1.2.3.30 | PROC | PROC |

| ID | WBS | Activity | Type | Duration | Start | Finish | Predecessors | Total float | Free float | Resources | Wajid | RPI_P2 - BOQ ITEMS | RPI_P2 - PROCUREMENT | RPI_P2 - PHASE |
| --- | --- | --- | --- | --- | --- | --- | --- | --- | --- | --- | --- | --- | --- | --- |
|  | 27 | **Mosaic Tiles (for Toilets)** |  |  | 2016-09-24 | 2017-02-26 |  |  |  |  |  |  |  |  |
| PR-Z3-GE-GE-233-0010 |  | RFQ - Mosaic Tiles (for Toilets) |  | 5.6d | 2016-09-24 | 2016-09-29 | PROC-GE-GE-GE-0010 FS+35d | 117.2d | 0d |  | OK | 1.2.3.30 | PROC | PROC |
| PR-Z3-GE-GE-233-0020 |  | Material Submittal - Mosaic Tiles (for Toilets) |  | 8d | 2016-09-29 | 2016-10-09 | PR-Z3-GE-GE-233-0010 | 117.2d | 0d |  | OK | 1.2.3.30 | PROC | PROC |
| PR-Z3-GE-GE-233-0030 |  | Material Approval - Mosaic Tiles (for Toilets) |  | 11.2d | 2016-10-09 | 2016-10-22 | PR-Z3-GE-GE-233-0020 | 117.2d | 0d |  | OK | 1.2.3.30 | PROC | PROC |
| PR-Z3-GE-GE-233-0040 |  | Technical Evaluation - Mosaic Tiles (for Toilets) |  | 8d | 2016-10-23 | 2016-10-31 | PR-Z3-GE-GE-233-0030 | 117.2d | 0d |  | OK | 1.2.3.30 | PROC | PROC |
| PR-Z3-GE-GE-233-0050 |  | PO - Mosaic Tiles (for Toilets) |  | 11.2d | 2016-11-01 | 2016-11-14 | PR-Z3-GE-GE-233-0040 | 117.2d | 0d |  | OK | 1.2.3.30 | PROC | PROC |
| PR-Z3-GE-GE-233-0060 |  | NMR 601 - Mosaic Tiles (for Toilets) |  | 4.8d | 2016-11-14 | 2016-11-19 | PR-Z3-GE-GE-233-0050 | 117.2d | 0d |  | OK | 1.2.3.30 | PROC | PROC |
| PR-Z3-GE-GE-233-0070 |  | NMR 602 - Mosaic Tiles (for Toilets) |  | 4.8d | 2016-11-20 | 2016-11-24 | PR-Z3-GE-GE-233-0060 | 117.2d | 0d |  | OK | 1.2.3.30 | PROC | PROC |
| PR-Z3-GE-GE-233-0080 |  | Start of Material Delivery - Mosaic Tiles (for Toilets) | milestone | 0d | 2017-02-02 | 2017-02-02 | PR-Z3-GE-GE-233-0070 FS+60d | 117.2d | 0d |  | OK | 1.2.3.30 | PROC | PROC |
| PR-Z3-GE-GE-233-0090 |  | Complete Material Delivery - Mosaic Tiles (for Toilets) |  | 12d | 2017-02-02 | 2017-02-16 | PR-Z3-GE-GE-233-0080 | 281.2d | 0d | Mosaic Tiles (for Toilets) [144 Sqm] | OK | 1.2.3.30 | PROC | PROC |
| PR-Z3-GE-GE-233-0100 |  | NMR 603 - Mosaic Tiles (for Toilets) |  | 8d | 2017-02-16 | 2017-02-26 | PR-Z3-GE-GE-233-0090 | 281.2d | 199d |  | OK | 1.2.3.30 | PROC | PROC |
|  | 28 | **Quarry Tiles (for Toilets)** |  |  | 2016-09-24 | 2017-02-26 |  |  |  |  |  |  |  |  |
| PR-Z3-GE-GE-234-0010 |  | RFQ - Quarry Tiles (for Toilets) |  | 5.6d | 2016-09-24 | 2016-09-29 | PR-Z3-GE-GE-233-0010 SS, PROC-GE-GE-GE-0010 FS+14.4d | 120.2d | 0d |  | OK | 1.2.3.30 | PROC | PROC |
| PR-Z3-GE-GE-234-0020 |  | Material Submittal - Quarry Tiles (for Toilets) |  | 8d | 2016-09-29 | 2016-10-09 | PR-Z3-GE-GE-234-0010 | 120.2d | 0d |  | OK | 1.2.3.30 | PROC | PROC |
| PR-Z3-GE-GE-234-0030 |  | Material Approval - Quarry Tiles (for Toilets) |  | 11.2d | 2016-10-09 | 2016-10-22 | PR-Z3-GE-GE-234-0020 | 120.2d | 0d |  | OK | 1.2.3.30 | PROC | PROC |
| PR-Z3-GE-GE-234-0040 |  | Technical Evaluation - Quarry Tiles (for Toilets) |  | 8d | 2016-10-23 | 2016-10-31 | PR-Z3-GE-GE-234-0030 | 120.2d | 0d |  | OK | 1.2.3.30 | PROC | PROC |
| PR-Z3-GE-GE-234-0050 |  | PO - Quarry Tiles (for Toilets) |  | 11.2d | 2016-11-01 | 2016-11-14 | PR-Z3-GE-GE-234-0040 | 120.2d | 0d |  | OK | 1.2.3.30 | PROC | PROC |
| PR-Z3-GE-GE-234-0060 |  | NMR 601 - Quarry Tiles (for Toilets) |  | 4.8d | 2016-11-14 | 2016-11-19 | PR-Z3-GE-GE-234-0050 | 120.2d | 0d |  | OK | 1.2.3.30 | PROC | PROC |
| PR-Z3-GE-GE-234-0070 |  | NMR 602 - Quarry Tiles (for Toilets) |  | 4.8d | 2016-11-20 | 2016-11-24 | PR-Z3-GE-GE-234-0060 | 120.2d | 0d |  | OK | 1.2.3.30 | PROC | PROC |
| PR-Z3-GE-GE-234-0080 |  | Start of Material Delivery - Quarry Tiles (for Toilets) | milestone | 0d | 2017-02-02 | 2017-02-02 | PR-Z3-GE-GE-234-0070 FS+60d | 120.2d | 0d |  | OK | 1.2.3.30 | PROC | PROC |
| PR-Z3-GE-GE-234-0090 |  | Complete Material Delivery - Quarry Tiles (for Toilets) |  | 12d | 2017-02-02 | 2017-02-16 | PR-Z3-GE-GE-234-0080 | 281.2d | 0d | Quarry Tiles (for Toilets) [36 Sqm] | OK | 1.2.3.30 | PROC | PROC |
| PR-Z3-GE-GE-234-0100 |  | NMR 603 - Quarry Tiles (for Toilets) |  | 8d | 2017-02-16 | 2017-02-26 | PR-Z3-GE-GE-234-0090 | 281.2d | 199d |  | OK | 1.2.3.30 | PROC | PROC |
|  | 29 | **Toilet Partitions (Phenolic 19 mm thick)** |  |  | 2016-09-24 | 2017-04-09 |  |  |  |  |  |  |  |  |
| PR-Z3-GE-GE-235-0010 |  | RFQ - Toilet Partitions (Phenolic 19 mm thick) |  | 5.6d | 2016-09-24 | 2016-09-29 | PROC-GE-GE-GE-0010 FS+35d | 164.2d | 0d |  | OK | 1.2.3.30 | PROC | PROC |
| PR-Z3-GE-GE-235-0020 |  | Material Submittal - Toilet Partitions (Phenolic 19 mm thick) |  | 8d | 2016-09-29 | 2016-10-09 | PR-Z3-GE-GE-235-0010 | 164.2d | 0d |  | OK | 1.2.3.30 | PROC | PROC |
| PR-Z3-GE-GE-235-0030 |  | Material Approval - Toilet Partitions (Phenolic 19 mm thick) |  | 11.2d | 2016-10-09 | 2016-10-22 | PR-Z3-GE-GE-235-0020 | 164.2d | 0d |  | OK | 1.2.3.30 | PROC | PROC |
| PR-Z3-GE-GE-235-0040 |  | Technical Evaluation - Toilet Partitions (Phenolic 19 mm thick) |  | 8d | 2016-10-23 | 2016-10-31 | PR-Z3-GE-GE-235-0030 | 164.2d | 0d |  | OK | 1.2.3.30 | PROC | PROC |
| PR-Z3-GE-GE-235-0050 |  | PO - Toilet Partitions (Phenolic 19 mm thick) |  | 11.2d | 2016-11-01 | 2016-11-14 | PR-Z3-GE-GE-235-0040 | 164.2d | 0d |  | OK | 1.2.3.30 | PROC | PROC |
| PR-Z3-GE-GE-235-0060 |  | NMR 601 - Toilet Partitions (Phenolic 19 mm thick) |  | 4.8d | 2016-11-14 | 2016-11-19 | PR-Z3-GE-GE-235-0050 | 164.2d | 0d |  | OK | 1.2.3.30 | PROC | PROC |
| PR-Z3-GE-GE-235-0070 |  | NMR 602 - Toilet Partitions (Phenolic 19 mm thick) |  | 4.8d | 2016-11-20 | 2016-11-24 | PR-Z3-GE-GE-235-0060 | 164.2d | 0d |  | OK | 1.2.3.30 | PROC | PROC |
| PR-Z3-GE-GE-235-0080 |  | Start of Material Delivery - Toilet Partitions (Phenolic 19 mm thick) | milestone | 0d | 2017-02-20 | 2017-02-20 | PR-Z3-GE-GE-235-0070 FS+75d | 164.2d | 0d |  | OK | 1.2.3.30 | PROC | PROC |
| PR-Z3-GE-GE-235-0090 |  | Complete Material Delivery - Toilet Partitions (Phenolic 19 mm thick) |  | 33d | 2017-02-20 | 2017-03-30 | PR-Z3-GE-GE-235-0080 | 245.2d | 0d | Toilet Partitions (Phenolic 19 mm thick) [76.58 Sqm] | OK | 1.2.3.30 | PROC | PROC |
| PR-Z3-GE-GE-235-0100 |  | NMR 603 - Toilet Partitions (Phenolic 19 mm thick) |  | 8d | 2017-03-30 | 2017-04-09 | PR-Z3-GE-GE-235-0090 | 245.2d | 163d |  | OK | 1.2.3.30 | PROC | PROC |

| ID | WBS | Activity | Type | Duration | Start | Finish | Predecessors | Total float | Free float | Resources | Cost | Wajid | RPI_P2 - BOQ ITEMS | RPI_P2 - PROCUREMENT | RPI_P2 - PHASE |
| --- | --- | --- | --- | --- | --- | --- | --- | --- | --- | --- | --- | --- | --- | --- | --- |
|  | 30 | **Avonite Counter top with Cabinet (Toilets)** |  |  | 2016-11-16 | 2017-04-03 |  |  |  |  |  |  |  |  |  |
| PR-Z3-GE-GE-236-0010 |  | RFQ - Avonite Counter top with Cabinet (Toilets) |  | 5.6d | 2016-11-16 | 2016-11-22 | PROC-GE-GE-GE-0010 FS+80.8d | 187.4d | 0d |  |  | OK | 1.2.3.30 | PROC | PROC |
| PR-Z3-GE-GE-236-0020 |  | Material Submittal - Avonite Counter top with Cabinet (Toilets) |  | 8d | 2016-11-22 | 2016-12-01 | PR-Z3-GE-GE-236-0010 | 187.4d | 0d |  |  | OK | 1.2.3.30 | PROC | PROC |
| PR-Z3-GE-GE-236-0030 |  | Material Approval - Avonite Counter top with Cabinet (Toilets) |  | 11.2d | 2016-12-01 | 2016-12-14 | PR-Z3-GE-GE-236-0020 | 187.4d | 0d |  |  | OK | 1.2.3.30 | PROC | PROC |
| PR-Z3-GE-GE-236-0040 |  | Technical Evaluation - Avonite Counter top with Cabinet (Toilets) |  | 8d | 2016-12-14 | 2016-12-24 | PR-Z3-GE-GE-236-0030 | 187.4d | 0d |  |  | OK | 1.2.3.30 | PROC | PROC |
| PR-Z3-GE-GE-236-0050 |  | PO - Avonite Counter top with Cabinet (Toilets) |  | 11.2d | 2016-12-24 | 2017-01-05 | PR-Z3-GE-GE-236-0040 | 187.4d | 0d |  |  | OK | 1.2.3.30 | PROC | PROC |
| PR-Z3-GE-GE-236-0060 |  | NMR 601 - Avonite Counter top with Cabinet (Toilets) |  | 4.8d | 2017-01-07 | 2017-01-11 | PR-Z3-GE-GE-236-0050 | 187.4d | 0d |  |  | OK | 1.2.3.30 | PROC | PROC |
| PR-Z3-GE-GE-236-0070 |  | NMR 602 - Avonite Counter top with Cabinet (Toilets) |  | 4.8d | 2017-01-11 | 2017-01-17 | PR-Z3-GE-GE-236-0060 | 187.4d | 0d |  |  | OK | 1.2.3.30 | PROC | PROC |
| PR-Z3-GE-GE-236-0080 |  | Start of Material Delivery - Avonite Counter top with Cabinet (Toilets) | milestone | 0d | 2017-02-23 | 2017-02-23 | PR-Z3-GE-GE-236-0070 FS+32d | 187.4d | 0d |  |  | OK | 1.2.3.30 | PROC | PROC |
| PR-Z3-GE-GE-236-0090 |  | Complete Material Delivery - Avonite Counter top with Cabinet (Toilets) |  | 25d | 2017-02-23 | 2017-03-25 | PR-Z3-GE-GE-236-0080 | 250.4d | 0d | Avonite Counter top with Cabinet (Toilets) [1 LS] |  | OK | 1.2.3.30 | PROC | PROC |
| PR-Z3-GE-GE-236-0100 |  | NMR 603 - Avonite Counter top with Cabinet (Toilets) |  | 8d | 2017-03-25 | 2017-04-03 | PR-Z3-GE-GE-236-0090 | 250.4d | 168.2d |  |  | OK | 1.2.3.30 | PROC | PROC |
|  | 31 | **Marl Fill (Drainage Ponds)** |  |  | 2016-08-17 | 2017-06-10 |  |  |  |  |  |  |  |  |  |
| PR-Z3-GE-GE-236-0110 |  | RFQ - Marl Fill (Drainage Ponds) |  | 6d | 2016-08-17 | 2016-08-23 | PROC-GE-GE-GE-0010 FS+7d | 192.8d | 0d |  |  | OK | 1.2.3.30 | PROC | PROC |
| PR-Z3-GE-GE-236-0120 |  | Material Submittal - Marl Fill (Drainage Ponds) |  | 4d | 2016-08-24 | 2016-08-28 | PR-Z3-GE-GE-236-0110 | 192.8d | 0d |  |  | OK | 1.2.3.30 | PROC | PROC |
| PR-Z3-GE-GE-236-0130 |  | Material Approval - Marl Fill (Drainage Ponds) |  | 4d | 2016-08-29 | 2016-09-01 | PR-Z3-GE-GE-236-0120 | 192.8d | 0d |  |  | OK | 1.2.3.30 | PROC | PROC |
| PR-Z3-GE-GE-236-0140 |  | Technical Evaluation - Marl Fill (Drainage Ponds) |  | 6d | 2016-09-03 | 2016-09-08 | PR-Z3-GE-GE-236-0130 | 192.8d | 0d |  |  | OK | 1.2.3.30 | PROC | PROC |
| PR-Z3-GE-GE-236-0150 |  | PO - Marl Fill (Drainage Ponds) |  | 8d | 2016-09-10 | 2016-09-24 | PR-Z3-GE-GE-236-0140 | 192.8d | 0d |  |  | OK | 1.2.3.30 | PROC | PROC |
| PR-Z3-GE-GE-236-0160 |  | NMR 601 - Marl Fill (Drainage Ponds) |  | 12d | 2016-09-24 | 2016-10-08 | PR-Z3-GE-GE-236-0150 | 192.8d | 0d |  |  | OK | 1.2.3.30 | PROC | PROC |
| PR-Z3-GE-GE-236-0170 |  | NMR 602 - Marl Fill (Drainage Ponds) |  | 12d | 2016-10-08 | 2016-10-22 | PR-Z3-GE-GE-236-0160 | 192.8d | 0d |  |  | OK | 1.2.3.30 | PROC | PROC |
| PR-Z3-GE-GE-236-0180 |  | Start of Material Delivery - Marl Fill (Drainage Ponds) | milestone | 0d | 2016-11-28 | 2016-11-28 | PR-Z3-GE-GE-236-0170 FS+32d | 192.8d | 0d |  |  | OK | 1.2.3.30 | PROC | PROC |
| PR-Z3-GE-GE-236-0190 |  | Complete Material Delivery - Marl Fill (Drainage Ponds) |  | 120d | 2017-01-07 | 2017-05-27 | PR-Z3-GE-GE-236-0180 FS+34d | 192.8d | 0d | Avonite Counter top with Cabinet (Toilets) [1 LS] |  | OK | 1.2.3.30 | PROC | PROC |
| PR-Z3-GE-GE-236-0200 |  | NMR 603 - Marl Fill (Drainage Ponds) |  | 12d | 2017-05-27 | 2017-06-10 | PR-Z3-GE-GE-236-0190 | 192.8d | 110.6d |  |  | OK | 1.2.3.30 | PROC | PROC |
|  | 2 | **ELECTRICAL WORKS - (MATERIAL)** |  |  | 2016-08-09 | 2017-05-18 |  |  |  |  |  |  |  |  |  |
|  | 1 | **Medium Voltage Cables** |  |  | 2016-08-17 | 2017-05-08 |  |  |  |  |  |  |  |  |  |
|  | 1 | **MV Cables** |  |  | 2016-09-18 | 2017-05-08 |  |  |  |  |  |  |  |  |  |
| PR-Z3-EW-EW-36-0010 |  | RFQ - MV Cables |  | 7d | 2016-09-18 | 2016-09-26 | PROC-GE-GE-GE-0010 FS+30d | 7.8d | 0d |  |  | OK | 1.2.4.10 | PROC | PROC |
| PR-Z3-EW-EW-36-0020 |  | Material Submittal - MV Cables |  | 10d | 2016-09-26 | 2016-10-08 | PR-Z3-EW-EW-36-0010 | 7.8d | 0d |  |  | OK | 1.2.4.10 | PROC | PROC |
| PR-Z3-EW-EW-36-0030 |  | Material Approval - MV Cables |  | 14d | 2016-10-08 | 2016-10-24 | PR-Z3-EW-EW-36-0020 | 7.8d | 0d |  |  | OK | 1.2.4.10 | PROC | PROC |
| PR-Z3-EW-EW-36-0040 |  | Technical Evaluation - MV Cables |  | 10d | 2016-10-24 | 2016-11-05 | PR-Z3-EW-EW-36-0030 | 7.8d | 0d |  |  | OK | 1.2.4.10 | PROC | PROC |
| PR-Z3-EW-EW-36-0050 |  | PO - MV Cables |  | 14d | 2016-11-05 | 2016-11-21 | PR-Z3-EW-EW-36-0040 | 7.8d | 0d |  |  | OK | 1.2.4.10 | PROC | PROC |
| PR-Z3-EW-EW-36-0060 |  | NMR 601 - MV Cables |  | 6d | 2016-11-21 | 2016-11-28 | PR-Z3-EW-EW-36-0050 | 7.8d | 0d |  |  | OK | 1.2.4.10 | PROC | PROC |
| PR-Z3-EW-EW-36-0070 |  | NMR 602 - MV Cables |  | 6d | 2016-11-28 | 2016-12-05 | PR-Z3-EW-EW-36-0060 | 7.8d | 0d |  |  | OK | 1.2.4.10 | PROC | PROC |
| PR-Z3-EW-EW-36-0080 |  | Start of Material Delivery - MV Cables | milestone | 0d | 2017-03-05 | 2017-03-05 | PR-Z3-EW-EW-36-0070 FS+77d | 7.8d | 0d |  |  | OK | 1.2.4.10 | PROC | PROC |
| PR-Z3-EW-EW-36-0090 |  | Complete Material Delivery - MV Cables |  | 45d | 2017-03-05 | 2017-04-26 | PR-Z3-EW-EW-36-0080 | 220.8d | 0d | MV Cables [4360 Lm] | 1,560,576.13 | OK | 1.2.4.10 | PROC | PROC |
| PR-Z3-EW-EW-36-0100 |  | NMR 603 - MV Cables |  | 10d | 2017-04-26 | 2017-05-08 | PR-Z3-EW-EW-36-0090 | 220.8d | 138.6d |  |  | OK | 1.2.4.10 | PROC | PROC |

Notes:
- PR-Z3-EW-EW-36-0090: Expenses: (New Expense Item) 1560576

| ID | WBS | Activity | Type | Duration | Start | Finish | Predecessors | Total float | Free float | Resources | Cost | Wajid | RPI_P2 - BOQ ITEMS | RPI_P2 - PROCUREMENT | RPI_P2 - PHASE |
| --- | --- | --- | --- | --- | --- | --- | --- | --- | --- | --- | --- | --- | --- | --- | --- |
|  | 2 | **MV Cables Splicing & Repairing Kits and Accessories** |  |  | 2016-09-18 | 2017-05-06 |  |  |  |  |  |  |  |  |  |
| PR-Z3-EW-EW-37-0010 |  | RFQ - MV Cables Splicing, Repairing Kits & Accessories |  | 7d | 2016-09-18 | 2016-09-26 | PR-Z3-EW-EW-36-0010 SS, PROC-GE-GE-GE-0010 FS+15.2d | 25.8d | 0d |  |  | OK | 1.2.4.10 | PROC | PROC |
| PR-Z3-EW-EW-37-0020 |  | Material Submittal - MV Cables Splicing, Repairing Kits & Accessories |  | 10d | 2016-09-26 | 2016-10-08 | PR-Z3-EW-EW-37-0010 | 25.8d | 0d |  |  | OK | 1.2.4.10 | PROC | PROC |
| PR-Z3-EW-EW-37-0030 |  | Material Approval - MV Cables Splicing, Repairing Kits & Accessories |  | 14d | 2016-10-08 | 2016-10-24 | PR-Z3-EW-EW-37-0020 | 25.8d | 0d |  |  | OK | 1.2.4.10 | PROC | PROC |
| PR-Z3-EW-EW-37-0040 |  | Technical Evaluation - MV Cables Splicing, Repairing Kits & Accessories |  | 10d | 2016-10-24 | 2016-11-05 | PR-Z3-EW-EW-37-0030 | 25.8d | 0d |  |  | OK | 1.2.4.10 | PROC | PROC |
| PR-Z3-EW-EW-37-0050 |  | PO - MV Cables Splicing, Repairing Kits & Accessories |  | 14d | 2016-11-05 | 2016-11-21 | PR-Z3-EW-EW-37-0040 | 25.8d | 0d |  |  | OK | 1.2.4.10 | PROC | PROC |
| PR-Z3-EW-EW-37-0060 |  | NMR 601 - MV Cables Splicing, Repairing Kits & Accessories |  | 6d | 2016-11-21 | 2016-11-28 | PR-Z3-EW-EW-37-0050 | 25.8d | 0d |  |  | OK | 1.2.4.10 | PROC | PROC |
| PR-Z3-EW-EW-37-0070 |  | NMR 602 - MV Cables Splicing, Repairing Kits & Accessories |  | 4d | 2016-11-28 | 2016-12-03 | PR-Z3-EW-EW-37-0060 | 25.8d | 0d |  |  | OK | 1.2.4.10 | PROC | PROC |
| PR-Z3-EW-EW-37-0080 |  | Start of Material Delivery - MV Cables Splicing, Repairing Kits & Accessories | milestone | 0d | 2017-03-02 | 2017-03-02 | PR-Z3-EW-EW-37-0070 FS+77d | 25.8d | 0d |  |  | OK | 1.2.4.10 | PROC | PROC |
| PR-Z3-EW-EW-37-0090 |  | Complete Material Delivery - MV Cables Splicing, Repairing Kits & Accessories |  | 45d | 2017-03-02 | 2017-04-24 | PR-Z3-EW-EW-37-0080 | 222.8d | 0d | MV Cables Splicing & Repairing Kits [1 ea] | 28,087.12 | OK | 1.2.4.10 | PROC | PROC |
| PR-Z3-EW-EW-37-0100 |  | NMR 603 - MV Cables Splicing, Repairing Kits & Accessories |  | 10d | 2017-04-24 | 2017-05-06 | PR-Z3-EW-EW-37-0090 | 222.8d | 140.6d |  |  | OK | 1.2.4.10 | PROC | PROC |
|  | 3 | **Grounding Cables & Accessories** |  |  | 2016-09-07 | 2017-03-14 |  |  |  |  |  |  |  |  |  |
| PR-Z3-EW-EW-38-0010 |  | RFQ - Grounding Cables & Accessories |  | 7d | 2016-09-07 | 2016-09-20 | PROC-GE-GE-GE-0010 FS+25d | 115.2d | 0d |  |  | OK | 1.2.4.10 | PROC | PROC |
| PR-Z3-EW-EW-38-0020 |  | Material Submittal - Grounding Cables & Accessories |  | 10d | 2016-09-20 | 2016-10-02 | PR-Z3-EW-EW-38-0010 | 135.4d | 0d |  |  | OK | 1.2.4.10 | PROC | PROC |
| PR-Z3-EW-EW-38-0030 |  | Material Approval - Grounding Cables & Accessories |  | 14d | 2016-10-02 | 2016-10-18 | PR-Z3-EW-EW-38-0020 | 135.4d | 0d |  |  | OK | 1.2.4.10 | PROC | PROC |
| PR-Z3-EW-EW-38-0040 |  | Technical Evaluation - Grounding Cables & Accessories |  | 10d | 2016-10-18 | 2016-10-30 | PR-Z3-EW-EW-38-0030 | 135.4d | 0d |  |  | OK | 1.2.4.10 | PROC | PROC |
| PR-Z3-EW-EW-38-0050 |  | PO - Grounding Cables & Accessories |  | 14d | 2016-10-30 | 2016-11-15 | PR-Z3-EW-EW-38-0040 | 135.4d | 0d |  |  | OK | 1.2.4.10 | PROC | PROC |
| PR-Z3-EW-EW-38-0060 |  | NMR 601 - Grounding Cables & Accessories |  | 6d | 2016-11-15 | 2016-11-22 | PR-Z3-EW-EW-38-0050 | 135.4d | 0d |  |  | OK | 1.2.4.10 | PROC | PROC |
| PR-Z3-EW-EW-38-0070 |  | NMR 602 - Grounding Cables & Accessories |  | 6d | 2016-11-22 | 2016-11-29 | PR-Z3-EW-EW-38-0060 | 135.4d | 0d |  |  | OK | 1.2.4.10 | PROC | PROC |
| PR-Z3-EW-EW-38-0080 |  | Start of Material Delivery - Grounding Cables & Accessories | milestone | 0d | 2017-02-13 | 2017-02-13 | PR-Z3-EW-EW-38-0070 FS+65d | 135.4d | 0d |  |  | OK | 1.2.4.10 | PROC | PROC |
| PR-Z3-EW-EW-38-0090 |  | Complete Material Delivery - Grounding Cables & Accessories |  | 15d | 2017-02-13 | 2017-03-02 | PR-Z3-EW-EW-38-0080 | 267.8d | 0d | Ground Cable and Accessories [5310 Lm] | 165,308.64 | OK | 1.2.4.10 | PROC | PROC |
| PR-Z3-EW-EW-38-0100 |  | NMR 603 - Grounding Cables & Accessories |  | 10d | 2017-03-02 | 2017-03-14 | PR-Z3-EW-EW-38-0090 | 267.8d | 185.6d |  |  | OK | 1.2.4.10 | PROC | PROC |
|  | 4 | **Sand for Backfilling** |  |  | 2016-08-17 | 2017-02-01 |  |  |  |  |  |  |  |  |  |
| PR-Z3-EW-EW-39-0010 |  | RFQ - Sand for Backfilling |  | 7d | 2016-08-17 | 2016-08-24 | PROC-GE-GE-GE-0010, PR-MT-Z1-LC-08-0010 SS | 302.8d | 0d |  |  | OK | 1.2.4.10 | PROC | PROC |
| PR-Z3-EW-EW-39-0020 |  | Material Submittal - Sand for Backfilling |  | 10d | 2016-08-25 | 2016-09-05 | PR-Z3-EW-EW-39-0010 | 302.8d | 0d |  |  | OK | 1.2.4.10 | PROC | PROC |
| PR-Z3-EW-EW-39-0030 |  | Material Approval - Sand for Backfilling |  | 14d | 2016-09-06 | 2016-09-27 | PR-Z3-EW-EW-39-0020 | 302.8d | 0d |  |  | OK | 1.2.4.10 | PROC | PROC |
| PR-Z3-EW-EW-39-0040 |  | Technical Evaluation - Sand for Backfilling |  | 10d | 2016-09-27 | 2016-10-09 | PR-Z3-EW-EW-39-0030 | 302.8d | 0d |  |  | OK | 1.2.4.10 | PROC | PROC |
| PR-Z3-EW-EW-39-0050 |  | PO - Sand for Backfilling |  | 14d | 2016-10-09 | 2016-10-25 | PR-Z3-EW-EW-39-0040 | 302.8d | 0d |  |  | OK | 1.2.4.10 | PROC | PROC |
| PR-Z3-EW-EW-39-0060 |  | NMR 601 - Sand for Backfilling |  | 6d | 2016-10-25 | 2016-11-01 | PR-Z3-EW-EW-39-0050 | 302.8d | 0d |  |  | OK | 1.2.4.10 | PROC | PROC |
| PR-Z3-EW-EW-39-0070 |  | NMR 602 - Sand for Backfilling |  | 6d | 2016-11-01 | 2016-11-08 | PR-Z3-EW-EW-39-0060 | 302.8d | 0d |  |  | OK | 1.2.4.10 | PROC | PROC |
| PR-Z3-EW-EW-39-0080 |  | Start of Material Delivery - Sand for Backfilling | milestone | 0d | 2016-11-23 | 2016-11-23 | PR-Z3-EW-EW-39-0070 FS+13d | 302.8d | 0d |  |  | OK | 1.2.4.10 | PROC | PROC |
| PR-Z3-EW-EW-39-0090 |  | Complete Material Delivery - Sand for Backfilling |  | 60d | 2016-11-23 | 2017-02-01 | PR-Z3-EW-EW-39-0080 | 302.8d | 220.6d | Sand for Backfilling [363.51 Cum] | 25,035.89 | OK | 1.2.4.10 | PROC | PROC |

Notes:
- PR-Z3-EW-EW-37-0090: Expenses: (New Expense Item) 28087.1
- PR-Z3-EW-EW-38-0090: Expenses: (New Expense Item) 165309
- PR-Z3-EW-EW-39-0090: Expenses: (New Expense Item) 25035.9

| ID | WBS | Activity | Type | Duration | Start | Finish | Predecessors | Total float | Free float | Resources | Cost | Wajid | RPI_P2 - BOQ ITEMS | RPI_P2 - PROCUREMENT | RPI_P2 - PHASE |
| --- | --- | --- | --- | --- | --- | --- | --- | --- | --- | --- | --- | --- | --- | --- | --- |
|  | 5 | **Warning Tapes** |  |  | 2016-08-28 | 2017-01-11 |  |  |  |  |  |  |  |  |  |
| PR-Z3-EW-EW-40-0010 |  | RFQ - Warning Tapes |  | 7d | 2016-08-28 | 2016-09-04 | PROC-GE-GE-GE-0010 FS+16d | 114.4d | 0d |  |  | OK | 1.2.4.10 | PROC | PROC |
| PR-Z3-EW-EW-40-0020 |  | Material Submittal - Warning Tapes |  | 10d | 2016-09-05 | 2016-09-21 | PR-Z3-EW-EW-40-0010 | 114.8d | 0d |  |  | OK | 1.2.4.10 | PROC | PROC |
| PR-Z3-EW-EW-40-0030 |  | Material Approval - Warning Tapes |  | 14d | 2016-09-21 | 2016-10-08 | PR-Z3-EW-EW-40-0020 | 114.8d | 0d |  |  | OK | 1.2.4.10 | PROC | PROC |
| PR-Z3-EW-EW-40-0040 |  | Technical Evaluation - Warning Tapes |  | 10d | 2016-10-08 | 2016-10-19 | PR-Z3-EW-EW-40-0030 | 114.8d | 0d |  |  | OK | 1.2.4.10 | PROC | PROC |
| PR-Z3-EW-EW-40-0050 |  | PO - Warning Tapes |  | 14d | 2016-10-19 | 2016-11-05 | PR-Z3-EW-EW-40-0040 | 114.8d | 0d |  |  | OK | 1.2.4.10 | PROC | PROC |
| PR-Z3-EW-EW-40-0060 |  | NMR 601 - Warning Tapes |  | 6d | 2016-11-05 | 2016-11-12 | PR-Z3-EW-EW-40-0050 | 114.8d | 0d |  |  | OK | 1.2.4.10 | PROC | PROC |
| PR-Z3-EW-EW-40-0070 |  | NMR 602 - Warning Tapes |  | 6d | 2016-11-12 | 2016-11-19 | PR-Z3-EW-EW-40-0060 | 114.8d | 0d |  |  | OK | 1.2.4.10 | PROC | PROC |
| PR-Z3-EW-EW-40-0080 |  | Start of Material Delivery - Warning Tapes | milestone | 0d | 2016-12-07 | 2016-12-07 | PR-Z3-EW-EW-40-0070 FS+16d | 114.8d | 0d |  |  | OK | 1.2.4.10 | PROC | PROC |
| PR-Z3-EW-EW-40-0090 |  | Complete Material Delivery - Warning Tapes |  | 30d | 2016-12-07 | 2017-01-11 | PR-Z3-EW-EW-40-0080 | 320.8d | 238.6d | Warning Tapes [4039 Lm] | 14,488.36 | OK | 1.2.4.10 | PROC | PROC |
|  | 6 | **Red Tiles** |  |  | 2016-08-28 | 2017-02-15 |  |  |  |  |  |  |  |  |  |
| PR-Z3-EW-EW-41-0010 |  | RFQ - Red Tiles |  | 7d | 2016-08-28 | 2016-09-04 | PROC-GE-GE-GE-0010 FS+16d | 290.8d | 0d |  |  | OK | 1.2.4.10 | PROC | PROC |
| PR-Z3-EW-EW-41-0020 |  | Material Submittal - Red Tiles |  | 10d | 2016-09-05 | 2016-09-21 | PR-Z3-EW-EW-41-0010 | 290.8d | 0d |  |  | OK | 1.2.4.10 | PROC | PROC |
| PR-Z3-EW-EW-41-0030 |  | Material Approval - Red Tiles |  | 14d | 2016-09-21 | 2016-10-08 | PR-Z3-EW-EW-41-0020 | 290.8d | 0d |  |  | OK | 1.2.4.10 | PROC | PROC |
| PR-Z3-EW-EW-41-0040 |  | Technical Evaluation - Red Tiles |  | 10d | 2016-10-08 | 2016-10-19 | PR-Z3-EW-EW-41-0030 | 290.8d | 0d |  |  | OK | 1.2.4.10 | PROC | PROC |
| PR-Z3-EW-EW-41-0050 |  | PO - Red Tiles |  | 14d | 2016-10-19 | 2016-11-05 | PR-Z3-EW-EW-41-0040 | 290.8d | 0d |  |  | OK | 1.2.4.10 | PROC | PROC |
| PR-Z3-EW-EW-41-0060 |  | NMR 601 - Red Tiles |  | 6d | 2016-11-05 | 2016-11-12 | PR-Z3-EW-EW-41-0050 | 290.8d | 0d |  |  | OK | 1.2.4.10 | PROC | PROC |
| PR-Z3-EW-EW-41-0070 |  | NMR 602 - Red Tiles |  | 6d | 2016-11-12 | 2016-11-19 | PR-Z3-EW-EW-41-0060 | 290.8d | 0d |  |  | OK | 1.2.4.10 | PROC | PROC |
| PR-Z3-EW-EW-41-0080 |  | Start of Material Delivery - Red Tiles | milestone | 0d | 2016-12-07 | 2016-12-07 | PR-Z3-EW-EW-41-0070 FS+16d | 290.8d | 0d |  |  | OK | 1.2.4.10 | PROC | PROC |
| PR-Z3-EW-EW-41-0090 |  | Complete Material Delivery - Red Tiles |  | 60d | 2016-12-07 | 2017-02-15 | PR-Z3-EW-EW-41-0080 | 290.8d | 208.6d | Red Tiles [20195 ea] | 72,441.8 | OK | 1.2.4.10 | PROC | PROC |
|  | 7 | **PVC Piles including Spacers (for Concrete Duct Banks)** |  |  | 2016-09-04 | 2016-12-25 |  |  |  |  |  |  |  |  |  |
| PR-Z3-EW-EW-42-0010 |  | RFQ - PVC Piles including Spacers (for Concrete Duct Banks) |  | 7d | 2016-09-04 | 2016-09-17 | PROC-GE-GE-GE-0010 FS+22.4d | 335.4d | 0d |  |  | OK | 1.2.4.10 | PROC | PROC |
| PR-Z3-EW-EW-42-0020 |  | Material Submittal - PVC Piles including Spacers (for Concrete Duct Banks) |  | 10d | 2016-09-17 | 2016-09-28 | PR-Z3-EW-EW-42-0010 | 335.4d | 0d |  |  | OK | 1.2.4.10 | PROC | PROC |
| PR-Z3-EW-EW-42-0030 |  | Material Approval - PVC Piles including Spacers (for Concrete Duct Banks) |  | 14d | 2016-09-28 | 2016-10-15 | PR-Z3-EW-EW-42-0020 | 335.4d | 0d |  |  | OK | 1.2.4.10 | PROC | PROC |
| PR-Z3-EW-EW-42-0040 |  | Technical Evaluation - PVC Piles including Spacers (for Concrete Duct Banks) |  | 10d | 2016-10-15 | 2016-10-26 | PR-Z3-EW-EW-42-0030 | 335.4d | 0d |  |  | OK | 1.2.4.10 | PROC | PROC |
| PR-Z3-EW-EW-42-0050 |  | PO - PVC Piles including Spacers (for Concrete Duct Banks) |  | 14d | 2016-10-26 | 2016-11-12 | PR-Z3-EW-EW-42-0040 | 335.4d | 0d |  |  | OK | 1.2.4.10 | PROC | PROC |
| PR-Z3-EW-EW-42-0060 |  | NMR 601 - PVC Piles including Spacers (for Concrete Duct Banks) |  | 6d | 2016-11-12 | 2016-11-19 | PR-Z3-EW-EW-42-0050 | 335.4d | 0d |  |  | OK | 1.2.4.10 | PROC | PROC |
| PR-Z3-EW-EW-42-0070 |  | NMR 602 - PVC Piles including Spacers (for Concrete Duct Banks) |  | 6d | 2016-11-19 | 2016-11-26 | PR-Z3-EW-EW-42-0060 | 335.4d | 0d |  |  | OK | 1.2.4.10 | PROC | PROC |
| PR-Z3-EW-EW-42-0080 |  | Start of Material Delivery - PVC Piles including Spacers (for Concrete Duct Banks) | milestone | 0d | 2016-11-26 | 2016-11-26 | PR-Z3-EW-EW-42-0070 | 335.4d | 0d |  |  | OK | 1.2.4.10 | PROC | PROC |
| PR-Z3-EW-EW-42-0090 |  | Complete Material Delivery - PVC Piles including Spacers (for Concrete Duct Banks) |  | 15d | 2016-11-26 | 2016-12-13 | PR-Z3-EW-EW-42-0080 | 335.4d | 0d | PVC Piles including Spacers [152 Lm] |  | OK | 1.2.4.10 | PROC | PROC |
| PR-Z3-EW-EW-42-0100 |  | NMR 603 - PVC Piles including Spacers (for Concrete Duct Banks) |  | 10d | 2016-12-13 | 2016-12-25 | PR-Z3-EW-EW-42-0090 | 335.4d | 253.2d |  |  | OK | 1.2.4.10 | PROC | PROC |

Notes:
- PR-Z3-EW-EW-40-0090: Expenses: (New Expense Item) 14488.4
- PR-Z3-EW-EW-41-0090: Expenses: (New Expense Item) 72441.8
- PR-Z3-EW-EW-42-0090: Expenses: (New Expense Item) 0

| ID | WBS | Activity | Type | Duration | Start | Finish | Predecessors | Total float | Free float | Resources | Cost | Wajid | RPI_P2 - BOQ ITEMS | RPI_P2 - PROCUREMENT | RPI_P2 - PHASE |
| --- | --- | --- | --- | --- | --- | --- | --- | --- | --- | --- | --- | --- | --- | --- | --- |
|  | 2 | **Motor Control Gear** |  |  | 2016-08-09 | 2017-05-08 |  |  |  |  |  |  |  |  |  |
|  | 1 | **10 M High Lighting Poles (for Lift Stations)** |  |  | 2016-09-18 | 2017-04-29 |  |  |  |  |  |  |  |  |  |
| PR-Z3-EW-EW-43-0010 |  | RFQ - 10 M High Lighting Poles (for Lift Stations) |  | 7d | 2016-09-18 | 2016-09-26 | PROC-GE-GE-GE-0010 FS+30d | 96.4d | 0d |  |  | OK | 1.2.4.20 | PROC | PROC |
| PR-Z3-EW-EW-43-0020 |  | Material Submittal - 10 M High Lighting Poles (for Lift Stations) |  | 10d | 2016-09-26 | 2016-10-08 | PR-Z3-EW-EW-43-0010 | 96.4d | 0d |  |  | OK | 1.2.4.20 | PROC | PROC |
| PR-Z3-EW-EW-43-0030 |  | Material Approval - 10 M High Lighting Poles (for Lift Stations) |  | 14d | 2016-10-08 | 2016-10-24 | PR-Z3-EW-EW-43-0020 | 96.4d | 0d |  |  | OK | 1.2.4.20 | PROC | PROC |
| PR-Z3-EW-EW-43-0040 |  | Technical Evaluation - 10 M High Lighting Poles (for Lift Stations) |  | 10d | 2016-10-24 | 2016-11-05 | PR-Z3-EW-EW-43-0030 | 96.4d | 0d |  |  | OK | 1.2.4.20 | PROC | PROC |
| PR-Z3-EW-EW-43-0050 |  | PO - 10 M High Lighting Poles (for Lift Stations) |  | 14d | 2016-11-05 | 2016-11-21 | PR-Z3-EW-EW-43-0040 | 96.4d | 0d |  |  | OK | 1.2.4.20 | PROC | PROC |
| PR-Z3-EW-EW-43-0060 |  | NMR 601 - 10 M High Lighting Poles (for Lift Stations) |  | 6d | 2016-11-21 | 2016-11-28 | PR-Z3-EW-EW-43-0050 | 96.4d | 0d |  |  | OK | 1.2.4.20 | PROC | PROC |
| PR-Z3-EW-EW-43-0070 |  | NMR 602 - 10 M High Lighting Poles (for Lift Stations) |  | 6d | 2016-11-28 | 2016-12-05 | PR-Z3-EW-EW-43-0060 | 96.4d | 0d |  |  | OK | 1.2.4.20 | PROC | PROC |
| PR-Z3-EW-EW-43-0080 |  | Start of Material Delivery - 10 M High Lighting Poles (for Lift Stations) | milestone | 0d | 2017-03-30 | 2017-03-30 | PR-Z3-EW-EW-43-0070 FS+99d | 96.4d | 0d |  |  | OK | 1.2.4.20 | PROC | PROC |
| PR-Z3-EW-EW-43-0090 |  | Complete Material Delivery - 10 M High Lighting Poles (for Lift Stations) |  | 15d | 2017-03-30 | 2017-04-17 | PR-Z3-EW-EW-43-0080 | 228.8d | 0d | 10 M High Lighting Poles [12 ea] | 24,298.87 | OK | 1.2.4.20 | PROC | PROC |
| PR-Z3-EW-EW-43-0100 |  | NMR 603 - 10 M High Lighting Poles (for Lift Stations) |  | 10d | 2017-04-17 | 2017-04-29 | PR-Z3-EW-EW-43-0090 | 228.8d | 146.6d |  |  | OK | 1.2.4.20 | PROC | PROC |
|  | 2 | **Lighting Fixtures incl. Explosion Proof Lighting Fixtures (for Lift Stations)** |  |  | 2016-09-19 | 2017-04-23 |  |  |  |  |  |  |  |  |  |
| PR-Z3-EW-EW-44-0010 |  | RFQ - Lighting Fixtures incl. Explosion Proof Lighting Fixtures (for Lift Stations) |  | 7d | 2016-09-19 | 2016-09-27 | PROC-GE-GE-GE-0010 FS+31.2d | 110d | 0d |  |  | OK | 1.2.4.20 | PROC | PROC |
| PR-Z3-EW-EW-44-0020 |  | Material Submittal - Lighting Fixtures incl. Explosion Proof Lighting Fixtures (for Lift Stations) |  | 10d | 2016-09-27 | 2016-10-09 | PR-Z3-EW-EW-44-0010 | 110d | 0d |  |  | OK | 1.2.4.20 | PROC | PROC |
| PR-Z3-EW-EW-44-0030 |  | Material Approval - Lighting Fixtures incl. Explosion Proof Lighting Fixtures (for Lift Stations) |  | 14d | 2016-10-09 | 2016-10-25 | PR-Z3-EW-EW-44-0020 | 110d | 0d |  |  | OK | 1.2.4.20 | PROC | PROC |
| PR-Z3-EW-EW-44-0040 |  | Technical Evaluation - Lighting Fixtures incl. Explosion Proof Lighting Fixtures (for Lift Stations) |  | 10d | 2016-10-25 | 2016-11-06 | PR-Z3-EW-EW-44-0030 | 110d | 0d |  |  | OK | 1.2.4.20 | PROC | PROC |
| PR-Z3-EW-EW-44-0050 |  | PO - Lighting Fixtures incl. Explosion Proof Lighting Fixtures (for Lift Stations) |  | 14d | 2016-11-06 | 2016-11-22 | PR-Z3-EW-EW-44-0040 | 110d | 0d |  |  | OK | 1.2.4.20 | PROC | PROC |
| PR-Z3-EW-EW-44-0060 |  | NMR 601 - Lighting Fixtures incl. Explosion Proof Lighting Fixtures (for Lift Stations) |  | 6d | 2016-11-22 | 2016-11-29 | PR-Z3-EW-EW-44-0050 | 110d | 0d |  |  | OK | 1.2.4.20 | PROC | PROC |
| PR-Z3-EW-EW-44-0070 |  | NMR 602 - Lighting Fixtures incl. Explosion Proof Lighting Fixtures (for Lift Stations) |  | 6d | 2016-11-29 | 2016-12-06 | PR-Z3-EW-EW-44-0060 | 110d | 0d |  |  | OK | 1.2.4.20 | PROC | PROC |
| PR-Z3-EW-EW-44-0080 |  | Start of Material Delivery - Lighting Fixtures incl. Explosion Proof Lighting Fixtures (for Lift Stations) | milestone | 0d | 2017-03-25 | 2017-03-25 | PR-Z3-EW-EW-44-0070 FS+93d | 110d | 0d |  |  | OK | 1.2.4.20 | PROC | PROC |
| PR-Z3-EW-EW-44-0090 |  | Complete Material Delivery - Lighting Fixtures incl. Explosion Proof Lighting Fixtures (for Lift Stations) |  | 15d | 2017-03-25 | 2017-04-11 | PR-Z3-EW-EW-44-0080 | 233.6d | 0d | Ligting Fixtures [16 ea] | 13,707.73 | OK | 1.2.4.20 | PROC | PROC |
| PR-Z3-EW-EW-44-0100 |  | NMR 603 - Lighting Fixtures incl. Explosion Proof Lighting Fixtures (for Lift Stations) |  | 10d | 2017-04-11 | 2017-04-23 | PR-Z3-EW-EW-44-0090 | 233.6d | 151.4d |  |  | OK | 1.2.4.20 | PROC | PROC |
|  | 3 | **Wiring Devices** |  |  | 2016-09-29 | 2017-05-02 |  |  |  |  |  |  |  |  |  |
| PR-Z3-EW-EW-45-0010 |  | RFQ - Wiring Devices |  | 7d | 2016-09-29 | 2016-10-08 | PROC-GE-GE-GE-0010 FS+40d | 225.8d | 0d |  |  | OK | 1.2.4.20 | PROC | PROC |
| PR-Z3-EW-EW-45-0020 |  | Material Submittal - Wiring Devices |  | 10d | 2016-10-08 | 2016-10-19 | PR-Z3-EW-EW-45-0010 | 225.8d | 0d |  |  | OK | 1.2.4.20 | PROC | PROC |
| PR-Z3-EW-EW-45-0030 |  | Material Approval - Wiring Devices |  | 14d | 2016-10-19 | 2016-11-05 | PR-Z3-EW-EW-45-0020 | 225.8d | 0d |  |  | OK | 1.2.4.20 | PROC | PROC |
| PR-Z3-EW-EW-45-0040 |  | Technical Evaluation - Wiring Devices |  | 10d | 2016-11-05 | 2016-11-16 | PR-Z3-EW-EW-45-0030 | 225.8d | 0d |  |  | OK | 1.2.4.20 | PROC | PROC |
| PR-Z3-EW-EW-45-0050 |  | PO - Wiring Devices |  | 14d | 2016-11-16 | 2016-12-03 | PR-Z3-EW-EW-45-0040 | 225.8d | 0d |  |  | OK | 1.2.4.20 | PROC | PROC |
| PR-Z3-EW-EW-45-0060 |  | NMR 601 - Wiring Devices |  | 6d | 2016-12-03 | 2016-12-10 | PR-Z3-EW-EW-45-0050 | 225.8d | 0d |  |  | OK | 1.2.4.20 | PROC | PROC |
| PR-Z3-EW-EW-45-0070 |  | NMR 602 - Wiring Devices |  | 6d | 2016-12-10 | 2016-12-17 | PR-Z3-EW-EW-45-0060 | 225.8d | 0d |  |  | OK | 1.2.4.20 | PROC | PROC |
| PR-Z3-EW-EW-45-0080 |  | Start of Material Delivery - Wiring Devices | milestone | 0d | 2017-04-03 | 2017-04-03 | PR-Z3-EW-EW-45-0070 FS+92d | 225.8d | 0d |  |  | OK | 1.2.4.20 | PROC | PROC |
| PR-Z3-EW-EW-45-0090 |  | Complete Material Delivery - Wiring Devices |  | 15d | 2017-04-03 | 2017-04-20 | PR-Z3-EW-EW-45-0080 | 225.8d | 0d | Wiring Devices [133 ea] | 8,835.84 | OK | 1.2.4.20 | PROC | PROC |
| PR-Z3-EW-EW-45-0100 |  | NMR 603 - Wiring Devices |  | 10d | 2017-04-20 | 2017-05-02 | PR-Z3-EW-EW-45-0090 | 225.8d | 143.6d |  |  | OK | 1.2.4.20 | PROC | PROC |

Notes:
- PR-Z3-EW-EW-43-0090: Expenses: (New Expense Item) 24298.9
- PR-Z3-EW-EW-44-0090: Expenses: (New Expense Item) 13707.7
- PR-Z3-EW-EW-45-0090: Expenses: (New Expense Item) 8835.84

| ID | WBS | Activity | Type | Duration | Start | Finish | Predecessors | Total float | Free float | Resources | Cost | Wajid | RPI_P2 - BOQ ITEMS | RPI_P2 - PROCUREMENT | RPI_P2 - PHASE |
| --- | --- | --- | --- | --- | --- | --- | --- | --- | --- | --- | --- | --- | --- | --- | --- |
|  | 4 | **MV Cables** |  |  | 2016-09-18 | 2017-05-08 |  |  |  |  |  |  |  |  |  |
| PR-Z3-EW-EW-46-0010 |  | RFQ - MV Cables |  | 7d | 2016-09-18 | 2016-09-26 | PROC-GE-GE-GE-0010 FS+11.2d, PR-Z3-EW-EW-36-0010 SS | 220.8d | 0d |  |  | OK | 1.2.4.20 | PROC | PROC |
| PR-Z3-EW-EW-46-0020 |  | Material Submittal - MV Cables |  | 10d | 2016-09-26 | 2016-10-08 | PR-Z3-EW-EW-46-0010 | 220.8d | 0d |  |  | OK | 1.2.4.20 | PROC | PROC |
| PR-Z3-EW-EW-46-0030 |  | Material Approval - MV Cables |  | 14d | 2016-10-08 | 2016-10-24 | PR-Z3-EW-EW-46-0020 | 220.8d | 0d |  |  | OK | 1.2.4.20 | PROC | PROC |
| PR-Z3-EW-EW-46-0040 |  | Technical Evaluation - MV Cables |  | 10d | 2016-10-24 | 2016-11-05 | PR-Z3-EW-EW-46-0030 | 220.8d | 0d |  |  | OK | 1.2.4.20 | PROC | PROC |
| PR-Z3-EW-EW-46-0050 |  | PO - MV Cables |  | 14d | 2016-11-05 | 2016-11-21 | PR-Z3-EW-EW-46-0040 | 220.8d | 0d |  |  | OK | 1.2.4.20 | PROC | PROC |
| PR-Z3-EW-EW-46-0060 |  | NMR 601 - MV Cables |  | 6d | 2016-11-21 | 2016-11-28 | PR-Z3-EW-EW-46-0050 | 220.8d | 0d |  |  | OK | 1.2.4.20 | PROC | PROC |
| PR-Z3-EW-EW-46-0070 |  | NMR 602 - MV Cables |  | 6d | 2016-11-28 | 2016-12-05 | PR-Z3-EW-EW-46-0060 | 220.8d | 0d |  |  | OK | 1.2.4.20 | PROC | PROC |
| PR-Z3-EW-EW-46-0080 |  | Start of Material Delivery - MV Cables | milestone | 0d | 2017-03-05 | 2017-03-05 | PR-Z3-EW-EW-46-0070 FS+77d | 220.8d | 0d |  |  | OK | 1.2.4.20 | PROC | PROC |
| PR-Z3-EW-EW-46-0090 |  | Complete Material Delivery - MV Cables |  | 45d | 2017-03-05 | 2017-04-26 | PR-Z3-EW-EW-46-0080 | 220.8d | 0d | MV Cables [739 Lm] | 33,843.19 | OK | 1.2.4.20 | PROC | PROC |
| PR-Z3-EW-EW-46-0100 |  | NMR 603 - MV Cables |  | 10d | 2017-04-26 | 2017-05-08 | PR-Z3-EW-EW-46-0090 | 220.8d | 138.6d |  |  | OK | 1.2.4.20 | PROC | PROC |
|  | 5 | **Cable Markers** |  |  | 2016-10-12 | 2017-04-16 |  |  |  |  |  |  |  |  |  |
| PR-Z3-EW-EW-47-0010 |  | RFQ - Cable Markers |  | 7d | 2016-10-12 | 2016-10-20 | PROC-GE-GE-GE-0010 FS+51.2d | 124.6d | 0d |  |  | OK | 1.2.4.20 | PROC | PROC |
| PR-Z3-EW-EW-47-0020 |  | Material Submittal - Cable Markers |  | 10d | 2016-10-20 | 2016-11-01 | PR-Z3-EW-EW-47-0010 | 124.6d | 0d |  |  | OK | 1.2.4.20 | PROC | PROC |
| PR-Z3-EW-EW-47-0030 |  | Material Approval - Cable Markers |  | 14d | 2016-11-01 | 2016-11-17 | PR-Z3-EW-EW-47-0020 | 124.6d | 0d |  |  | OK | 1.2.4.20 | PROC | PROC |
| PR-Z3-EW-EW-47-0040 |  | Technical Evaluation - Cable Markers |  | 10d | 2016-11-17 | 2016-11-29 | PR-Z3-EW-EW-47-0030 | 124.6d | 0d |  |  | OK | 1.2.4.20 | PROC | PROC |
| PR-Z3-EW-EW-47-0050 |  | PO - Cable Markers |  | 14d | 2016-11-29 | 2016-12-15 | PR-Z3-EW-EW-47-0040 | 124.6d | 0d |  |  | OK | 1.2.4.20 | PROC | PROC |
| PR-Z3-EW-EW-47-0060 |  | NMR 601 - Cable Markers |  | 6d | 2016-12-15 | 2016-12-22 | PR-Z3-EW-EW-47-0050 | 124.6d | 0d |  |  | OK | 1.2.4.20 | PROC | PROC |
| PR-Z3-EW-EW-47-0070 |  | NMR 602 - Cable Markers |  | 6d | 2016-12-22 | 2016-12-29 | PR-Z3-EW-EW-47-0060 | 124.6d | 0d |  |  | OK | 1.2.4.20 | PROC | PROC |
| PR-Z3-EW-EW-47-0080 |  | Start of Material Delivery - Cable Markers | milestone | 0d | 2017-03-18 | 2017-03-18 | PR-Z3-EW-EW-47-0070 FS+67d | 124.6d | 0d |  |  | OK | 1.2.4.20 | PROC | PROC |
| PR-Z3-EW-EW-47-0090 |  | Complete Material Delivery - Cable Markers |  | 15d | 2017-03-18 | 2017-04-04 | PR-Z3-EW-EW-47-0080 | 239.6d | 0d | Cable Markers [3 ea] | 1,053.74 | OK | 1.2.4.20 | PROC | PROC |
| PR-Z3-EW-EW-47-0100 |  | NMR 603 - Cable Markers |  | 10d | 2017-04-04 | 2017-04-16 | PR-Z3-EW-EW-47-0090 | 239.6d | 157.4d |  |  | OK | 1.2.4.20 | PROC | PROC |
|  | 6 | **MCC Panels (for Lift Stations)** |  |  | 2016-09-18 | 2017-04-30 |  |  |  |  |  |  |  |  |  |
| PR-Z3-EW-EW-48-0010 |  | RFQ - MCC Panels (for Lift Stations) |  | 7d | 2016-09-18 | 2016-09-26 | PROC-GE-GE-GE-0010 FS+30d | 87.4d | 0d |  |  | OK | 1.2.4.20 | PROC | PROC |
| PR-Z3-EW-EW-48-0020 |  | Material Submittal - MCC Panels (for Lift Stations) |  | 10d | 2016-09-26 | 2016-10-08 | PR-Z3-EW-EW-48-0010 | 87.4d | 0d |  |  | OK | 1.2.4.20 | PROC | PROC |
| PR-Z3-EW-EW-48-0030 |  | Material Approval - MCC Panels (for Lift Stations) |  | 14d | 2016-10-08 | 2016-10-24 | PR-Z3-EW-EW-48-0020 | 87.4d | 0d |  |  | OK | 1.2.4.20 | PROC | PROC |
| PR-Z3-EW-EW-48-0040 |  | Technical Evaluation - MCC Panels (for Lift Stations) |  | 10d | 2016-10-24 | 2016-11-05 | PR-Z3-EW-EW-48-0030 | 87.4d | 0d |  |  | OK | 1.2.4.20 | PROC | PROC |
| PR-Z3-EW-EW-48-0050 |  | PO - MCC Panels (for Lift Stations) |  | 14d | 2016-11-05 | 2016-11-21 | PR-Z3-EW-EW-48-0040 | 87.4d | 0d |  |  | OK | 1.2.4.20 | PROC | PROC |
| PR-Z3-EW-EW-48-0060 |  | NMR 601 - MCC Panels (for Lift Stations) |  | 6d | 2016-11-21 | 2016-11-28 | PR-Z3-EW-EW-48-0050 | 87.4d | 0d |  |  | OK | 1.2.4.20 | PROC | PROC |
| PR-Z3-EW-EW-48-0070 |  | NMR 602 - MCC Panels (for Lift Stations) |  | 6d | 2016-11-28 | 2016-12-05 | PR-Z3-EW-EW-48-0060 | 87.4d | 0d |  |  | OK | 1.2.4.20 | PROC | PROC |
| PR-Z3-EW-EW-48-0080 |  | Start of Material Delivery - MCC Panels (for Lift Stations) | milestone | 0d | 2017-04-01 | 2017-04-01 | PR-Z3-EW-EW-48-0070 FS+100d | 87.4d | 0d |  |  | OK | 1.2.4.20 | PROC | PROC |
| PR-Z3-EW-EW-48-0090 |  | Complete Material Delivery - MCC Panels (for Lift Stations) |  | 15d | 2017-04-01 | 2017-04-18 | PR-Z3-EW-EW-48-0080 | 227.8d | 0d | MCC Panels [2 ea] | 468,330.73 | OK | 1.2.4.20 | PROC | PROC |
| PR-Z3-EW-EW-48-0100 |  | NMR 603 - MCC Panels (for Lift Stations) |  | 10d | 2017-04-18 | 2017-04-30 | PR-Z3-EW-EW-48-0090 | 227.8d | 145.6d |  |  | OK | 1.2.4.20 | PROC | PROC |

Notes:
- PR-Z3-EW-EW-46-0090: Expenses: (New Expense Item) 33843.2
- PR-Z3-EW-EW-47-0090: Expenses: (New Expense Item) 1053.74
- PR-Z3-EW-EW-48-0090: Expenses: (New Expense Item) 468331

| ID | WBS | Activity | Type | Duration | Start | Finish | Predecessors | Total float | Free float | Resources | Cost | Wajid | RPI_P2 - BOQ ITEMS | RPI_P2 - PROCUREMENT | RPI_P2 - PHASE |
| --- | --- | --- | --- | --- | --- | --- | --- | --- | --- | --- | --- | --- | --- | --- | --- |
|  | 7 | **Sand for Backfilling** |  |  | 2016-08-09 | 2017-02-05 |  |  |  |  |  |  |  |  |  |
| PR-Z3-EW-EW-49-0010 |  | RFQ - Sand for Backfilling |  | 7d | 2016-08-09 | 2016-08-16 | PROC-GE-GE-GE-0010 | 299.8d | 0d |  |  | OK | 1.2.4.20 | PROC | PROC |
| PR-Z3-EW-EW-49-0020 |  | Material Submittal - Sand for Backfilling |  | 10d | 2016-08-17 | 2016-08-28 | PR-Z3-EW-EW-49-0010 | 299.8d | 0d |  |  | OK | 1.2.4.20 | PROC | PROC |
| PR-Z3-EW-EW-49-0030 |  | Material Approval - Sand for Backfilling |  | 14d | 2016-08-29 | 2016-09-19 | PR-Z3-EW-EW-49-0020 | 299.8d | 0d |  |  | OK | 1.2.4.20 | PROC | PROC |
| PR-Z3-EW-EW-49-0040 |  | Technical Evaluation - Sand for Backfilling |  | 10d | 2016-09-19 | 2016-10-01 | PR-Z3-EW-EW-49-0030 | 299.8d | 0d |  |  | OK | 1.2.4.20 | PROC | PROC |
| PR-Z3-EW-EW-49-0050 |  | PO - Sand for Backfilling |  | 14d | 2016-10-01 | 2016-10-17 | PR-Z3-EW-EW-49-0040 | 299.8d | 0d |  |  | OK | 1.2.4.20 | PROC | PROC |
| PR-Z3-EW-EW-49-0060 |  | NMR 601 - Sand for Backfilling |  | 6d | 2016-10-17 | 2016-10-24 | PR-Z3-EW-EW-49-0050 | 299.8d | 0d |  |  | OK | 1.2.4.20 | PROC | PROC |
| PR-Z3-EW-EW-49-0070 |  | NMR 602 - Sand for Backfilling |  | 6d | 2016-10-24 | 2016-10-31 | PR-Z3-EW-EW-49-0060 | 299.8d | 0d |  |  | OK | 1.2.4.20 | PROC | PROC |
| PR-Z3-EW-EW-49-0080 |  | Start of Material Delivery - Sand for Backfilling | milestone | 0d | 2016-11-15 | 2016-11-15 | PR-Z3-EW-EW-49-0070 FS+13d | 299.8d | 0d |  |  | OK | 1.2.4.20 | PROC | PROC |
| PR-Z3-EW-EW-49-0090 |  | Complete Material Delivery - Sand for Backfilling |  | 60d | 2016-11-15 | 2017-01-24 | PR-Z3-EW-EW-49-0080 | 299.8d | 0d | Sand for Backfilling [29.1 Cum] | 2,180.55 | OK | 1.2.4.20 | PROC | PROC |
| PR-Z3-EW-EW-49-0100 |  | NMR 603 - Sand for Backfilling |  | 10d | 2017-01-24 | 2017-02-05 | PR-Z3-EW-EW-49-0090 | 299.8d | 217.6d |  |  | OK | 1.2.4.20 | PROC | PROC |
|  | 8 | **Red Tiles** |  |  | 2016-08-28 | 2017-02-09 |  |  |  |  |  |  |  |  |  |
| PR-Z3-EW-EW-50-0010 |  | RFQ - Red Tiles |  | 7d | 2016-08-28 | 2016-09-04 | PR-Z3-EW-EW-41-0010 SS, PROC-GE-GE-GE-0010 FS+16d | 295.8d | 0d |  |  | OK | 1.2.4.20 | PROC | PROC |
| PR-Z3-EW-EW-50-0020 |  | Material Submittal - Red Tiles |  | 10d | 2016-09-05 | 2016-09-21 | PR-Z3-EW-EW-50-0010 | 295.8d | 0d |  |  | OK | 1.2.4.20 | PROC | PROC |
| PR-Z3-EW-EW-50-0030 |  | Material Approval - Red Tiles |  | 14d | 2016-09-21 | 2016-10-08 | PR-Z3-EW-EW-50-0020 | 295.8d | 0d |  |  | OK | 1.2.4.20 | PROC | PROC |
| PR-Z3-EW-EW-50-0040 |  | Technical Evaluation - Red Tiles |  | 10d | 2016-10-08 | 2016-10-19 | PR-Z3-EW-EW-50-0030 | 295.8d | 0d |  |  | OK | 1.2.4.20 | PROC | PROC |
| PR-Z3-EW-EW-50-0050 |  | PO - Red Tiles |  | 14d | 2016-10-19 | 2016-11-05 | PR-Z3-EW-EW-50-0040 | 295.8d | 0d |  |  | OK | 1.2.4.20 | PROC | PROC |
| PR-Z3-EW-EW-50-0060 |  | NMR 601 - Red Tiles |  | 6d | 2016-11-05 | 2016-11-12 | PR-Z3-EW-EW-50-0050 | 295.8d | 0d |  |  | OK | 1.2.4.20 | PROC | PROC |
| PR-Z3-EW-EW-50-0070 |  | NMR 602 - Red Tiles |  | 6d | 2016-11-12 | 2016-11-19 | PR-Z3-EW-EW-50-0060 | 295.8d | 0d |  |  | OK | 1.2.4.20 | PROC | PROC |
| PR-Z3-EW-EW-50-0080 |  | Start of Material Delivery - Red Tiles | milestone | 0d | 2016-12-07 | 2016-12-07 | PR-Z3-EW-EW-50-0070 FS+16d | 295.8d | 0d |  |  | OK | 1.2.4.20 | PROC | PROC |
| PR-Z3-EW-EW-50-0090 |  | Complete Material Delivery - Red Tiles |  | 45d | 2016-12-07 | 2017-01-29 | PR-Z3-EW-EW-50-0080 | 295.8d | 0d | Red Tiles [625 ea] | 2,439.22 | OK | 1.2.4.20 | PROC | PROC |
| PR-Z3-EW-EW-50-0100 |  | NMR 603 - Red Tiles |  | 10d | 2017-01-29 | 2017-02-09 | PR-Z3-EW-EW-50-0090 | 295.8d | 213.6d |  |  | OK | 1.2.4.20 | PROC | PROC |
|  | 9 | **Warning Tapes** |  |  | 2016-08-28 | 2017-01-23 |  |  |  |  |  |  |  |  |  |
| PR-Z3-EW-EW-51-0010 |  | RFQ - Warning Tapes |  | 7d | 2016-08-28 | 2016-09-04 | PROC-GE-GE-GE-0010 FS+16d | 310.8d | 0d |  |  | OK | 1.2.4.20 | PROC | PROC |
| PR-Z3-EW-EW-51-0020 |  | Material Submittal - Warning Tapes |  | 10d | 2016-09-05 | 2016-09-21 | PR-Z3-EW-EW-51-0010 | 310.8d | 0d |  |  | OK | 1.2.4.20 | PROC | PROC |
| PR-Z3-EW-EW-51-0030 |  | Material Approval - Warning Tapes |  | 14d | 2016-09-21 | 2016-10-08 | PR-Z3-EW-EW-51-0020 | 310.8d | 0d |  |  | OK | 1.2.4.20 | PROC | PROC |
| PR-Z3-EW-EW-51-0040 |  | Technical Evaluation - Warning Tapes |  | 10d | 2016-10-08 | 2016-10-19 | PR-Z3-EW-EW-51-0030 | 310.8d | 0d |  |  | OK | 1.2.4.20 | PROC | PROC |
| PR-Z3-EW-EW-51-0050 |  | PO - Warning Tapes |  | 14d | 2016-10-19 | 2016-11-05 | PR-Z3-EW-EW-51-0040 | 310.8d | 0d |  |  | OK | 1.2.4.20 | PROC | PROC |
| PR-Z3-EW-EW-51-0060 |  | NMR 601 - Warning Tapes |  | 6d | 2016-11-05 | 2016-11-12 | PR-Z3-EW-EW-51-0050 | 310.8d | 0d |  |  | OK | 1.2.4.20 | PROC | PROC |
| PR-Z3-EW-EW-51-0070 |  | NMR 602 - Warning Tapes |  | 6d | 2016-11-12 | 2016-11-19 | PR-Z3-EW-EW-51-0060 | 310.8d | 0d |  |  | OK | 1.2.4.20 | PROC | PROC |
| PR-Z3-EW-EW-51-0080 |  | Start of Material Delivery - Warning Tapes | milestone | 0d | 2016-12-07 | 2016-12-07 | PR-Z3-EW-EW-51-0070 FS+16d | 310.8d | 0d |  |  | OK | 1.2.4.20 | PROC | PROC |
| PR-Z3-EW-EW-51-0090 |  | Complete Material Delivery - Warning Tapes |  | 30d | 2016-12-07 | 2017-01-11 | PR-Z3-EW-EW-51-0080 | 310.8d | 0d | Warning Tapes [133 Lm] | 519.07 | OK | 1.2.4.20 | PROC | PROC |
| PR-Z3-EW-EW-51-0100 |  | NMR 603 - Warning Tapes |  | 10d | 2017-01-11 | 2017-01-23 | PR-Z3-EW-EW-51-0090 | 310.8d | 228.6d |  |  | OK | 1.2.4.20 | PROC | PROC |

Notes:
- PR-Z3-EW-EW-49-0090: Expenses: (New Expense Item) 2180.55
- PR-Z3-EW-EW-50-0090: Expenses: (New Expense Item) 2439.22
- PR-Z3-EW-EW-51-0090: Expenses: (New Expense Item) 519.07

| ID | WBS | Activity | Type | Duration | Start | Finish | Predecessors | Total float | Free float | Resources | Cost | Wajid | RPI_P2 - BOQ ITEMS | RPI_P2 - PROCUREMENT | RPI_P2 - PHASE |
| --- | --- | --- | --- | --- | --- | --- | --- | --- | --- | --- | --- | --- | --- | --- | --- |
|  | 10 | **Disconnect Switches - Outdoor type (for Lift Stations)** |  |  | 2016-09-29 | 2017-05-02 |  |  |  |  |  |  |  |  |  |
| PR-Z3-EW-EW-52-0010 |  | RFQ - Disconnect Switches (Outdoor Type) |  | 7d | 2016-09-29 | 2016-10-08 | PROC-GE-GE-GE-0010 FS+40d | 225.8d | 0d |  |  | OK | 1.2.4.20 | PROC | PROC |
| PR-Z3-EW-EW-52-0020 |  | Material Submittal - Disconnect Switches (Outdoor Type) |  | 10d | 2016-10-08 | 2016-10-19 | PR-Z3-EW-EW-52-0010 | 225.8d | 0d |  |  | OK | 1.2.4.20 | PROC | PROC |
| PR-Z3-EW-EW-52-0030 |  | Material Approval - Disconnect Switches (Outdoor Type) |  | 14d | 2016-10-19 | 2016-11-05 | PR-Z3-EW-EW-52-0020 | 225.8d | 0d |  |  | OK | 1.2.4.20 | PROC | PROC |
| PR-Z3-EW-EW-52-0040 |  | Technical Evaluation - Disconnect Switches (Outdoor Type) |  | 10d | 2016-11-05 | 2016-11-16 | PR-Z3-EW-EW-52-0030 | 225.8d | 0d |  |  | OK | 1.2.4.20 | PROC | PROC |
| PR-Z3-EW-EW-52-0050 |  | PO - Disconnect Switches (Outdoor Type) |  | 14d | 2016-11-16 | 2016-12-03 | PR-Z3-EW-EW-52-0040 | 225.8d | 0d |  |  | OK | 1.2.4.20 | PROC | PROC |
| PR-Z3-EW-EW-52-0060 |  | NMR 601 - Disconnect Switches (Outdoor Type) |  | 6d | 2016-12-03 | 2016-12-10 | PR-Z3-EW-EW-52-0050 | 225.8d | 0d |  |  | OK | 1.2.4.20 | PROC | PROC |
| PR-Z3-EW-EW-52-0070 |  | NMR 602 - Disconnect Switches (Outdoor Type) |  | 6d | 2016-12-10 | 2016-12-17 | PR-Z3-EW-EW-52-0060 | 225.8d | 0d |  |  | OK | 1.2.4.20 | PROC | PROC |
| PR-Z3-EW-EW-52-0080 |  | Start of Material Delivery - Disconnect Switches (Outdoor Type) | milestone | 0d | 2017-04-03 | 2017-04-03 | PR-Z3-EW-EW-52-0070 FS+92d | 225.8d | 0d |  |  | OK | 1.2.4.20 | PROC | PROC |
| PR-Z3-EW-EW-52-0090 |  | Complete Material Delivery - Disconnect Switches (Outdoor Type) |  | 15d | 2017-04-03 | 2017-04-20 | PR-Z3-EW-EW-52-0080 | 225.8d | 0d | Disconnect Switches [4 ea] | 14,596.31 | OK | 1.2.4.20 | PROC | PROC |
| PR-Z3-EW-EW-52-0100 |  | NMR 603 - Disconnect Switches (Outdoor Type) |  | 10d | 2017-04-20 | 2017-05-02 | PR-Z3-EW-EW-52-0090 | 225.8d | 143.6d |  |  | OK | 1.2.4.20 | PROC | PROC |
|  | 11 | **PVC Coated Conduits including Accessories** |  |  | 2016-09-04 | 2016-12-25 |  |  |  |  |  |  |  |  |  |
| PR-Z3-EW-EW-53-0010 |  | RFQ - PVC Coated Conduits including Accessories |  | 7d | 2016-09-04 | 2016-09-17 | PROC-GE-GE-GE-0010 FS+22.4d | 335.4d | 0d |  |  | OK | 1.2.4.20 | PROC | PROC |
| PR-Z3-EW-EW-53-0020 |  | Material Submittal - PVC Coated Conduits including Accessories |  | 10d | 2016-09-17 | 2016-09-28 | PR-Z3-EW-EW-53-0010 | 335.4d | 0d |  |  | OK | 1.2.4.20 | PROC | PROC |
| PR-Z3-EW-EW-53-0030 |  | Material Approval - PVC Coated Conduits including Accessories |  | 14d | 2016-09-28 | 2016-10-15 | PR-Z3-EW-EW-53-0020 | 335.4d | 0d |  |  | OK | 1.2.4.20 | PROC | PROC |
| PR-Z3-EW-EW-53-0040 |  | Technical Evaluation - PVC Coated Conduits including Accessories |  | 10d | 2016-10-15 | 2016-10-26 | PR-Z3-EW-EW-53-0030 | 335.4d | 0d |  |  | OK | 1.2.4.20 | PROC | PROC |
| PR-Z3-EW-EW-53-0050 |  | PO - PVC Coated Conduits including Accessories |  | 14d | 2016-10-26 | 2016-11-12 | PR-Z3-EW-EW-53-0040 | 335.4d | 0d |  |  | OK | 1.2.4.20 | PROC | PROC |
| PR-Z3-EW-EW-53-0060 |  | NMR 601 - PVC Coated Conduits including Accessories |  | 6d | 2016-11-12 | 2016-11-19 | PR-Z3-EW-EW-53-0050 | 335.4d | 0d |  |  | OK | 1.2.4.20 | PROC | PROC |
| PR-Z3-EW-EW-53-0070 |  | NMR 602 - PVC Coated Conduits including Accessories |  | 6d | 2016-11-19 | 2016-11-26 | PR-Z3-EW-EW-53-0060 | 335.4d | 0d |  |  | OK | 1.2.4.20 | PROC | PROC |
| PR-Z3-EW-EW-53-0080 |  | Start of Material Delivery - PVC Coated Conduits including Accessories | milestone | 0d | 2016-11-26 | 2016-11-26 | PR-Z3-EW-EW-53-0070 | 335.4d | 0d |  |  | OK | 1.2.4.20 | PROC | PROC |
| PR-Z3-EW-EW-53-0090 |  | Complete Material Delivery - PVC Coated Conduits including Accessories |  | 15d | 2016-11-26 | 2016-12-13 | PR-Z3-EW-EW-53-0080 | 335.4d | 0d | PVC Coated Conduits including Accessories [911 Lm] | 53,252.33 | OK | 1.2.4.20 | PROC | PROC |
| PR-Z3-EW-EW-53-0100 |  | NMR 603 - PVC Coated Conduits including Accessories |  | 10d | 2016-12-13 | 2016-12-25 | PR-Z3-EW-EW-53-0090 | 335.4d | 253.2d |  |  | OK | 1.2.4.20 | PROC | PROC |
|  | 12 | **Grounding Cables & Accessories** |  |  | 2016-09-07 | 2017-03-14 |  |  |  |  |  |  |  |  |  |
| PR-Z3-EW-EW-54-0010 |  | RFQ - Grounding Cables & Accessories |  | 7d | 2016-09-07 | 2016-09-20 | PROC-GE-GE-GE-0010 FS+7.2d, PR-Z3-EW-EW-38-0010 SS | 267.8d | 0d |  |  | OK | 1.2.4.20 | PROC | PROC |
| PR-Z3-EW-EW-54-0020 |  | Material Submittal - Grounding Cables & Accessories |  | 10d | 2016-09-20 | 2016-10-02 | PR-Z3-EW-EW-54-0010 | 267.8d | 0d |  |  | OK | 1.2.4.20 | PROC | PROC |
| PR-Z3-EW-EW-54-0030 |  | Material Approval - Grounding Cables & Accessories |  | 14d | 2016-10-02 | 2016-10-18 | PR-Z3-EW-EW-54-0020 | 267.8d | 0d |  |  | OK | 1.2.4.20 | PROC | PROC |
| PR-Z3-EW-EW-54-0040 |  | Technical Evaluation - Grounding Cables & Accessories |  | 10d | 2016-10-18 | 2016-10-30 | PR-Z3-EW-EW-54-0030 | 267.8d | 0d |  |  | OK | 1.2.4.20 | PROC | PROC |
| PR-Z3-EW-EW-54-0050 |  | PO - Grounding Cables & Accessories |  | 14d | 2016-10-30 | 2016-11-15 | PR-Z3-EW-EW-54-0040 | 267.8d | 0d |  |  | OK | 1.2.4.20 | PROC | PROC |
| PR-Z3-EW-EW-54-0060 |  | NMR 601 - Grounding Cables & Accessories |  | 6d | 2016-11-15 | 2016-11-22 | PR-Z3-EW-EW-54-0050 | 267.8d | 0d |  |  | OK | 1.2.4.20 | PROC | PROC |
| PR-Z3-EW-EW-54-0070 |  | NMR 602 - Grounding Cables & Accessories |  | 6d | 2016-11-22 | 2016-11-29 | PR-Z3-EW-EW-54-0060 | 267.8d | 0d |  |  | OK | 1.2.4.20 | PROC | PROC |
| PR-Z3-EW-EW-54-0080 |  | Start of Material Delivery - Grounding Cables & Accessories | milestone | 0d | 2017-02-13 | 2017-02-13 | PR-Z3-EW-EW-54-0070 FS+65d | 267.8d | 0d |  |  | OK | 1.2.4.20 | PROC | PROC |
| PR-Z3-EW-EW-54-0090 |  | Complete Material Delivery - Grounding Cables & Accessories |  | 15d | 2017-02-13 | 2017-03-02 | PR-Z3-EW-EW-54-0080 | 267.8d | 0d | Ground Cable and Accessories [1711 Lm] | 36,088 | OK | 1.2.4.20 | PROC | PROC |
| PR-Z3-EW-EW-54-0100 |  | NMR 603 - Grounding Cables & Accessories |  | 10d | 2017-03-02 | 2017-03-14 | PR-Z3-EW-EW-54-0090 | 267.8d | 185.6d |  |  | OK | 1.2.4.20 | PROC | PROC |

Notes:
- PR-Z3-EW-EW-52-0090: Expenses: (New Expense Item) 14596.3
- PR-Z3-EW-EW-53-0090: Expenses: (New Expense Item) 53252.3
- PR-Z3-EW-EW-54-0090: Expenses: (New Expense Item) 36088

| ID | WBS | Activity | Type | Duration | Start | Finish | Predecessors | Total float | Free float | Resources | Cost | Wajid | RPI_P2 - BOQ ITEMS | RPI_P2 - PROCUREMENT | RPI_P2 - PHASE |
| --- | --- | --- | --- | --- | --- | --- | --- | --- | --- | --- | --- | --- | --- | --- | --- |
|  | 13 | **LV Cables including Fire Alarm Cables (for Lift Stations)** |  |  | 2016-09-03 | 2017-03-09 |  |  |  |  |  |  |  |  |  |
| PR-Z3-EW-EW-55-0010 |  | RFQ - LV Cables including Fire Alarm Cables (for Lift Stations) |  | 7d | 2016-09-03 | 2016-09-15 | PROC-GE-GE-GE-0010 FS+12.8d, PR-MT-Z1-LC-11-0010 SS | 117d | 0d |  |  | OK | 1.2.4.20 | PROC | PROC |
| PR-Z3-EW-EW-55-0020 |  | Material Submittal - LV Cables including Fire Alarm Cables (for Lift Stations) |  | 10d | 2016-09-15 | 2016-09-27 | PR-Z3-EW-EW-55-0010 | 117d | 0d |  |  | OK | 1.2.4.20 | PROC | PROC |
| PR-Z3-EW-EW-55-0030 |  | Material Approval - LV Cables including Fire Alarm Cables (for Lift Stations) |  | 14d | 2016-09-27 | 2016-10-13 | PR-Z3-EW-EW-55-0020 | 117d | 0d |  |  | OK | 1.2.4.20 | PROC | PROC |
| PR-Z3-EW-EW-55-0040 |  | Technical Evaluation - LV Cables including Fire Alarm Cables (for Lift Stations) |  | 10d | 2016-10-13 | 2016-10-25 | PR-Z3-EW-EW-55-0030 | 117d | 0d |  |  | OK | 1.2.4.20 | PROC | PROC |
| PR-Z3-EW-EW-55-0050 |  | PO - LV Cables including Fire Alarm Cables (for Lift Stations) |  | 14d | 2016-10-25 | 2016-11-10 | PR-Z3-EW-EW-55-0040 | 117d | 0d |  |  | OK | 1.2.4.20 | PROC | PROC |
| PR-Z3-EW-EW-55-0060 |  | NMR 601 - LV Cables including Fire Alarm Cables (for Lift Stations) |  | 6d | 2016-11-10 | 2016-11-17 | PR-Z3-EW-EW-55-0050 | 117d | 0d |  |  | OK | 1.2.4.20 | PROC | PROC |
| PR-Z3-EW-EW-55-0070 |  | NMR 602 - LV Cables including Fire Alarm Cables (for Lift Stations) |  | 6d | 2016-11-17 | 2016-11-24 | PR-Z3-EW-EW-55-0060 | 117d | 0d |  |  | OK | 1.2.4.20 | PROC | PROC |
| PR-Z3-EW-EW-55-0080 |  | Start of Material Delivery - LV Cables including Fire Alarm Cables (for Lift Stations) | milestone | 0d | 2017-02-08 | 2017-02-08 | PR-Z3-EW-EW-55-0070 FS+65d | 117d | 0d |  |  | OK | 1.2.4.20 | PROC | PROC |
| PR-Z3-EW-EW-55-0090 |  | Complete Material Delivery - LV Cables including Fire Alarm Cables (for Lift Stations) |  | 15d | 2017-02-08 | 2017-02-26 | PR-Z3-EW-EW-55-0080 | 271.8d | 0d | LV Cables [1380 Lm] | 14,399.61 | OK | 1.2.4.20 | PROC | PROC |
| PR-Z3-EW-EW-55-0100 |  | NMR 603 - LV Cables including Fire Alarm Cables (for Lift Stations) |  | 10d | 2017-02-26 | 2017-03-09 | PR-Z3-EW-EW-55-0090 | 271.8d | 189.6d |  |  | OK | 1.2.4.20 | PROC | PROC |
|  | 14 | **Instrumentation Materials** |  |  | 2016-10-05 | 2017-05-04 |  |  |  |  |  |  |  |  |  |
| PR-Z3-EW-EW-56-0010 |  | RFQ - Instrumentation Materials |  | 7d | 2016-10-05 | 2016-10-13 | PROC-GE-GE-GE-0010 FS+45d | 223.8d | 0d |  |  | OK | 1.2.4.20 | PROC | PROC |
| PR-Z3-EW-EW-56-0020 |  | Material Submittal - Instrumentation Materials |  | 10d | 2016-10-13 | 2016-10-25 | PR-Z3-EW-EW-56-0010 | 223.8d | 0d |  |  | OK | 1.2.4.20 | PROC | PROC |
| PR-Z3-EW-EW-56-0030 |  | Material Approval - Instrumentation Materials |  | 14d | 2016-10-25 | 2016-11-10 | PR-Z3-EW-EW-56-0020 | 223.8d | 0d |  |  | OK | 1.2.4.20 | PROC | PROC |
| PR-Z3-EW-EW-56-0040 |  | Technical Evaluation - Instrumentation Materials |  | 10d | 2016-11-10 | 2016-11-22 | PR-Z3-EW-EW-56-0030 | 223.8d | 0d |  |  | OK | 1.2.4.20 | PROC | PROC |
| PR-Z3-EW-EW-56-0050 |  | PO - Instrumentation Materials |  | 14d | 2016-11-22 | 2016-12-08 | PR-Z3-EW-EW-56-0040 | 223.8d | 0d |  |  | OK | 1.2.4.20 | PROC | PROC |
| PR-Z3-EW-EW-56-0060 |  | NMR 601 - Instrumentation Materials |  | 6d | 2016-12-08 | 2016-12-15 | PR-Z3-EW-EW-56-0050 | 223.8d | 0d |  |  | OK | 1.2.4.20 | PROC | PROC |
| PR-Z3-EW-EW-56-0070 |  | NMR 602 - Instrumentation Materials |  | 6d | 2016-12-15 | 2016-12-22 | PR-Z3-EW-EW-56-0060 | 223.8d | 0d |  |  | OK | 1.2.4.20 | PROC | PROC |
| PR-Z3-EW-EW-56-0080 |  | Start of Material Delivery - Instrumentation Materials | milestone | 0d | 2017-04-05 | 2017-04-05 | PR-Z3-EW-EW-56-0070 FS+89d | 223.8d | 0d |  |  | OK | 1.2.4.20 | PROC | PROC |
| PR-Z3-EW-EW-56-0090 |  | Complete Material Delivery - Instrumentation Materials |  | 15d | 2017-04-05 | 2017-04-23 | PR-Z3-EW-EW-56-0080 | 223.8d | 0d | Instrumentation Materials [1 LS] | 280,998.44 | OK | 1.2.4.20 | PROC | PROC |
| PR-Z3-EW-EW-56-0100 |  | NMR 603 - Instrumentation Materials |  | 10d | 2017-04-23 | 2017-05-04 | PR-Z3-EW-EW-56-0090 | 223.8d | 141.6d |  |  | OK | 1.2.4.20 | PROC | PROC |
|  | 3 | **Street Lighting, Solar Lighting Fixtures** |  |  | 2016-09-19 | 2017-05-10 |  |  |  |  |  |  |  |  |  |
|  | 1 | **Walkway Lighting Fixtures** |  |  | 2016-09-19 | 2017-04-29 |  |  |  |  |  |  |  |  |  |
| PR-Z3-EW-EW-57-0010 |  | RFQ - Walkway Lighting Fixtures |  | 7d | 2016-09-19 | 2016-09-27 | PROC-GE-GE-GE-0010 FS+31.2d | 228.6d | 0d |  |  | OK | 1.2.4.30 | PROC | PROC |
| PR-Z3-EW-EW-57-0020 |  | Material Submittal - Walkway Lighting Fixtures |  | 10d | 2016-09-27 | 2016-10-09 | PR-Z3-EW-EW-57-0010 | 228.6d | 0d |  |  | OK | 1.2.4.30 | PROC | PROC |
| PR-Z3-EW-EW-57-0030 |  | Material Approval - Walkway Lighting Fixtures |  | 14d | 2016-10-09 | 2016-10-25 | PR-Z3-EW-EW-57-0020 | 228.6d | 0d |  |  | OK | 1.2.4.30 | PROC | PROC |
| PR-Z3-EW-EW-57-0040 |  | Technical Evaluation - Walkway Lighting Fixtures |  | 10d | 2016-10-25 | 2016-11-06 | PR-Z3-EW-EW-57-0030 | 228.6d | 0d |  |  | OK | 1.2.4.30 | PROC | PROC |
| PR-Z3-EW-EW-57-0050 |  | PO - Walkway Lighting Fixtures |  | 14d | 2016-11-06 | 2016-11-22 | PR-Z3-EW-EW-57-0040 | 228.6d | 0d |  |  | OK | 1.2.4.30 | PROC | PROC |
| PR-Z3-EW-EW-57-0060 |  | NMR 601 - Walkway Lighting Fixtures |  | 6d | 2016-11-22 | 2016-11-29 | PR-Z3-EW-EW-57-0050 | 228.6d | 0d |  |  | OK | 1.2.4.30 | PROC | PROC |
| PR-Z3-EW-EW-57-0070 |  | NMR 602 - Walkway Lighting Fixtures |  | 6d | 2016-11-29 | 2016-12-06 | PR-Z3-EW-EW-57-0060 | 228.6d | 0d |  |  | OK | 1.2.4.30 | PROC | PROC |
| PR-Z3-EW-EW-57-0080 |  | Start of Material Delivery - Walkway Lighting Fixtures | milestone | 0d | 2017-03-25 | 2017-03-25 | PR-Z3-EW-EW-57-0070 FS+93d | 228.6d | 0d |  |  | OK | 1.2.4.30 | PROC | PROC |
| PR-Z3-EW-EW-57-0090 |  | Complete Material Delivery - Walkway Lighting Fixtures |  | 20d | 2017-03-25 | 2017-04-17 | PR-Z3-EW-EW-57-0080 | 228.6d | 0d | Ligting Fixtures [715 ea] | 6,355,758.51 | OK | 1.2.4.30 | PROC | PROC |
| PR-Z3-EW-EW-57-0100 |  | NMR 603 - Walkway Lighting Fixtures |  | 10d | 2017-04-17 | 2017-04-29 | PR-Z3-EW-EW-57-0090 | 228.6d | 146.4d |  |  | OK | 1.2.4.30 | PROC | PROC |

Notes:
- PR-Z3-EW-EW-55-0090: Expenses: (New Expense Item) 14399.6
- PR-Z3-EW-EW-56-0090: Expenses: (New Expense Item) 280998
- PR-Z3-EW-EW-57-0090: Expenses: (New Expense Item) 6355759

| ID | WBS | Activity | Type | Duration | Start | Finish | Predecessors | Total float | Free float | Resources | Cost | Wajid | RPI_P2 - BOQ ITEMS | RPI_P2 - PROCUREMENT | RPI_P2 - PHASE |
| --- | --- | --- | --- | --- | --- | --- | --- | --- | --- | --- | --- | --- | --- | --- | --- |
|  | 2 | **Concrete Foundations (Lighting Fixtures)** |  |  | 2016-09-19 | 2017-05-10 |  |  |  |  |  |  |  |  |  |
| PR-Z3-EW-EW-58-0010 |  | RFQ - Concrete Foundations (Lighting Fixtures) |  | 7d | 2016-09-19 | 2016-09-27 | PROC-GE-GE-GE-0010 FS+31.2d | 73d | 0d |  |  | OK | 1.2.4.30 | PROC | PROC |
| PR-Z3-EW-EW-58-0020 |  | Material Submittal - Concrete Foundations (Lighting Fixtures) |  | 10d | 2016-09-27 | 2016-10-09 | PR-Z3-EW-EW-58-0010 | 73d | 0d |  |  | OK | 1.2.4.30 | PROC | PROC |
| PR-Z3-EW-EW-58-0030 |  | Material Approval - Concrete Foundations (Lighting Fixtures) |  | 14d | 2016-10-09 | 2016-10-25 | PR-Z3-EW-EW-58-0020 | 73d | 0d |  |  | OK | 1.2.4.30 | PROC | PROC |
| PR-Z3-EW-EW-58-0040 |  | Technical Evaluation - Concrete Foundations (Lighting Fixtures) |  | 10d | 2016-10-25 | 2016-11-06 | PR-Z3-EW-EW-58-0030 | 73d | 0d |  |  | OK | 1.2.4.30 | PROC | PROC |
| PR-Z3-EW-EW-58-0050 |  | PO - Concrete Foundations (Lighting Fixtures) |  | 14d | 2016-11-06 | 2016-11-22 | PR-Z3-EW-EW-58-0040 | 73d | 0d |  |  | OK | 1.2.4.30 | PROC | PROC |
| PR-Z3-EW-EW-58-0060 |  | NMR 601 - Concrete Foundations (Lighting Fixtures) |  | 6d | 2016-11-22 | 2016-11-29 | PR-Z3-EW-EW-58-0050 | 73d | 0d |  |  | OK | 1.2.4.30 | PROC | PROC |
| PR-Z3-EW-EW-58-0070 |  | NMR 602 - Concrete Foundations (Lighting Fixtures) |  | 6d | 2017-03-18 | 2017-03-25 | PR-Z3-EW-EW-58-0060 FS+93d | 73d | 0d |  |  | OK | 1.2.4.30 | PROC | PROC |
| PR-Z3-EW-EW-58-0080 |  | Start of Material Delivery - Concrete Foundations (Lighting Fixtures) | milestone | 0d | 2017-03-25 | 2017-03-25 | PR-Z3-EW-EW-58-0070 | 73d | 0d |  |  | OK | 1.2.4.30 | PROC | PROC |
| PR-Z3-EW-EW-58-0090 |  | Complete Material Delivery - Concrete Foundations (Lighting Fixtures) |  | 30d | 2017-03-25 | 2017-04-29 | PR-Z3-EW-EW-58-0080 | 218.6d | 0d | Concrete Foundation [1525 ea] | 662,275.12 | OK | 1.2.4.30 | PROC | PROC |
| PR-Z3-EW-EW-58-0100 |  | NMR 603 - Concrete Foundations (Lighting Fixtures) |  | 10d | 2017-04-29 | 2017-05-10 | PR-Z3-EW-EW-58-0090 | 218.6d | 136.4d |  |  | OK | 1.2.4.30 | PROC | PROC |
|  | 4 | **Miscellaneous Electrical Items** |  |  | 2016-09-07 | 2017-05-18 |  |  |  |  |  |  |  |  |  |
|  | 1 | **LV & MV Cables Accessories** |  |  | 2016-09-18 | 2017-04-03 |  |  |  |  |  |  |  |  |  |
| PR-Z3-EW-ME-59-0010 |  | RFQ - LV & MV Cables Accessories |  | 7d | 2016-09-18 | 2016-09-26 | PROC-GE-GE-GE-0010 FS+8d, PR-Z3-EW-EW-36-0010 SS | 250.8d | 0d |  |  | OK | 1.2.4.40 | PROC | PROC |
| PR-Z3-EW-ME-59-0020 |  | Material Submittal - LV & MV Cables Accessories |  | 10d | 2016-09-26 | 2016-10-08 | PR-Z3-EW-ME-59-0010 | 250.8d | 0d |  |  | OK | 1.2.4.40 | PROC | PROC |
| PR-Z3-EW-ME-59-0030 |  | Material Approval - LV & MV Cables Accessories |  | 14d | 2016-10-08 | 2016-10-24 | PR-Z3-EW-ME-59-0020 | 250.8d | 0d |  |  | OK | 1.2.4.40 | PROC | PROC |
| PR-Z3-EW-ME-59-0040 |  | Technical Evaluation - LV & MV Cables Accessories |  | 10d | 2016-10-24 | 2016-11-05 | PR-Z3-EW-ME-59-0030 | 250.8d | 0d |  |  | OK | 1.2.4.40 | PROC | PROC |
| PR-Z3-EW-ME-59-0050 |  | PO - LV & MV Cables Accessories |  | 14d | 2016-11-05 | 2016-11-21 | PR-Z3-EW-ME-59-0040 | 250.8d | 0d |  |  | OK | 1.2.4.40 | PROC | PROC |
| PR-Z3-EW-ME-59-0060 |  | NMR 601 - LV & MV Cables Accessories |  | 6d | 2016-11-21 | 2016-11-28 | PR-Z3-EW-ME-59-0050 | 250.8d | 0d |  |  | OK | 1.2.4.40 | PROC | PROC |
| PR-Z3-EW-ME-59-0070 |  | NMR 602 - LV & MV Cables Accessories |  | 6d | 2016-11-28 | 2016-12-05 | PR-Z3-EW-ME-59-0060 | 250.8d | 0d |  |  | OK | 1.2.4.40 | PROC | PROC |
| PR-Z3-EW-ME-59-0080 |  | Start of Material Delivery - LV & MV Cables Accessories | milestone | 0d | 2017-03-05 | 2017-03-05 | PR-Z3-EW-ME-59-0070 FS+77d | 250.8d | 0d |  |  | OK | 1.2.4.40 | PROC | PROC |
| PR-Z3-EW-ME-59-0090 |  | Complete Material Delivery - LV & MV Cables Accessories |  | 15d | 2017-03-05 | 2017-03-22 | PR-Z3-EW-ME-59-0080 | 250.8d | 0d | LV & MV Cable Accessories [1 Lm] | 558,065.84 | OK | 1.2.4.40 | PROC | PROC |
| PR-Z3-EW-ME-59-0100 |  | NMR 603 - LV & MV Cables Accessories |  | 10d | 2017-03-22 | 2017-04-03 | PR-Z3-EW-ME-59-0090 | 250.8d | 168.6d |  |  | OK | 1.2.4.40 | PROC | PROC |
|  | 2 | **Grounding Cables & Accessories** |  |  | 2016-09-07 | 2017-03-14 |  |  |  |  |  |  |  |  |  |
| PR-Z3-EW-ME-60-0010 |  | RFQ - Grounding Cables & Accessories |  | 7d | 2016-09-07 | 2016-09-20 | PROC-GE-GE-GE-0010 FS+7.2d, PR-Z3-EW-EW-38-0010 SS | 267.8d | 0d |  |  | OK | 1.2.4.40 | PROC | PROC |
| PR-Z3-EW-ME-60-0020 |  | Material Submittal - Grounding Cables & Accessories |  | 10d | 2016-09-20 | 2016-10-02 | PR-Z3-EW-ME-60-0010 | 267.8d | 0d |  |  | OK | 1.2.4.40 | PROC | PROC |
| PR-Z3-EW-ME-60-0030 |  | Material Approval - Grounding Cables & Accessories |  | 14d | 2016-10-02 | 2016-10-18 | PR-Z3-EW-ME-60-0020 | 267.8d | 0d |  |  | OK | 1.2.4.40 | PROC | PROC |
| PR-Z3-EW-ME-60-0040 |  | Technical Evaluation - Grounding Cables & Accessories |  | 10d | 2016-10-18 | 2016-10-30 | PR-Z3-EW-ME-60-0030 | 267.8d | 0d |  |  | OK | 1.2.4.40 | PROC | PROC |
| PR-Z3-EW-ME-60-0050 |  | PO - Grounding Cables & Accessories |  | 14d | 2016-10-30 | 2016-11-15 | PR-Z3-EW-ME-60-0040 | 267.8d | 0d |  |  | OK | 1.2.4.40 | PROC | PROC |
| PR-Z3-EW-ME-60-0060 |  | NMR 601 - Grounding Cables & Accessories |  | 6d | 2016-11-15 | 2016-11-22 | PR-Z3-EW-ME-60-0050 | 267.8d | 0d |  |  | OK | 1.2.4.40 | PROC | PROC |
| PR-Z3-EW-ME-60-0070 |  | NMR 602 - Grounding Cables & Accessories |  | 6d | 2016-11-22 | 2016-11-29 | PR-Z3-EW-ME-60-0060 | 267.8d | 0d |  |  | OK | 1.2.4.40 | PROC | PROC |
| PR-Z3-EW-ME-60-0080 |  | Start of Material Delivery - Grounding Cables & Accessories | milestone | 0d | 2017-02-13 | 2017-02-13 | PR-Z3-EW-ME-60-0070 FS+65d | 267.8d | 0d |  |  | OK | 1.2.4.40 | PROC | PROC |
| PR-Z3-EW-ME-60-0090 |  | Complete Material Delivery - Grounding Cables & Accessories |  | 15d | 2017-02-13 | 2017-03-02 | PR-Z3-EW-ME-60-0080 | 267.8d | 0d | Ground Cable and Accessories [252 Lm] | 41,932 | OK | 1.2.4.40 | PROC | PROC |
| PR-Z3-EW-ME-60-0100 |  | NMR 603 - Grounding Cables & Accessories |  | 10d | 2017-03-02 | 2017-03-14 | PR-Z3-EW-ME-60-0090 | 267.8d | 185.6d |  |  | OK | 1.2.4.40 | PROC | PROC |

Notes:
- PR-Z3-EW-EW-58-0090: Expenses: (New Expense Item) 662275
- PR-Z3-EW-ME-59-0090: Expenses: (New Expense Item) 558066
- PR-Z3-EW-ME-60-0090: Expenses: (New Expense Item) 41932

| ID | WBS | Activity | Type | Duration | Start | Finish | Predecessors | Total float | Free float | Resources | Cost | Wajid | RPI_P2 - BOQ ITEMS | RPI_P2 - PROCUREMENT | RPI_P2 - PHASE |
| --- | --- | --- | --- | --- | --- | --- | --- | --- | --- | --- | --- | --- | --- | --- | --- |
|  | 3 | **Wiring Devices (for Shelters)** |  |  | 2016-09-29 | 2017-05-02 |  |  |  |  |  |  |  |  |  |
| PR-Z3-EW-ME-61-0010 |  | RFQ - Wiring Devices (for Shelters) |  | 7d | 2016-09-29 | 2016-10-08 | PROC-GE-GE-GE-0010 FS+40d | 129.8d | 0d |  |  | OK | 1.2.4.40 | PROC | PROC |
| PR-Z3-EW-ME-61-0020 |  | Material Submittal - Wiring Devices (for Shelters) |  | 10d | 2016-10-08 | 2016-10-19 | PR-Z3-EW-ME-61-0010 | 129.8d | 0d |  |  | OK | 1.2.4.40 | PROC | PROC |
| PR-Z3-EW-ME-61-0030 |  | Material Approval - Wiring Devices (for Shelters) |  | 14d | 2016-10-19 | 2016-11-05 | PR-Z3-EW-ME-61-0020 | 129.8d | 0d |  |  | OK | 1.2.4.40 | PROC | PROC |
| PR-Z3-EW-ME-61-0040 |  | Technical Evaluation - Wiring Devices (for Shelters) |  | 10d | 2016-11-05 | 2016-11-16 | PR-Z3-EW-ME-61-0030 | 129.8d | 0d |  |  | OK | 1.2.4.40 | PROC | PROC |
| PR-Z3-EW-ME-61-0050 |  | PO - Wiring Devices (for Shelters) |  | 14d | 2016-11-16 | 2016-12-03 | PR-Z3-EW-ME-61-0040 | 129.8d | 0d |  |  | OK | 1.2.4.40 | PROC | PROC |
| PR-Z3-EW-ME-61-0060 |  | NMR 601 - Wiring Devices (for Shelters) |  | 6d | 2016-12-03 | 2016-12-10 | PR-Z3-EW-ME-61-0050 | 129.8d | 0d |  |  | OK | 1.2.4.40 | PROC | PROC |
| PR-Z3-EW-ME-61-0070 |  | NMR 602 - Wiring Devices (for Shelters) |  | 6d | 2016-12-10 | 2016-12-17 | PR-Z3-EW-ME-61-0060 | 129.8d | 0d |  |  | OK | 1.2.4.40 | PROC | PROC |
| PR-Z3-EW-ME-61-0080 |  | Start of Material Delivery - Wiring Devices (for Shelters) | milestone | 0d | 2017-04-03 | 2017-04-03 | PR-Z3-EW-ME-61-0070 FS+92d | 129.8d | 0d |  |  | OK | 1.2.4.40 | PROC | PROC |
| PR-Z3-EW-ME-61-0090 |  | Complete Material Delivery - Wiring Devices (for Shelters) |  | 15d | 2017-04-03 | 2017-04-20 | PR-Z3-EW-ME-61-0080 | 225.8d | 0d | Wiring Devices [186 ea] | 38,510.57 | OK | 1.2.4.40 | PROC | PROC |
| PR-Z3-EW-ME-61-0100 |  | NMR 603 - Wiring Devices (for Shelters) |  | 10d | 2017-04-20 | 2017-05-02 | PR-Z3-EW-ME-61-0090 | 225.8d | 143.6d |  |  | OK | 1.2.4.40 | PROC | PROC |
|  | 4 | **Disconnect Switches** |  |  | 2016-09-29 | 2017-05-02 |  |  |  |  |  |  |  |  |  |
| PR-Z3-EW-ME-62-0010 |  | RFQ - Disconnect Switches |  | 7d | 2016-09-29 | 2016-10-08 | PROC-GE-GE-GE-0010 FS+40d | 30.2d | 0d |  |  | OK | 1.2.4.40 | PROC | PROC |
| PR-Z3-EW-ME-62-0020 |  | Material Submittal - Disconnect Switches |  | 10d | 2016-10-08 | 2016-10-19 | PR-Z3-EW-ME-62-0010 | 30.2d | 0d |  |  | OK | 1.2.4.40 | PROC | PROC |
| PR-Z3-EW-ME-62-0030 |  | Material Approval - Disconnect Switches |  | 14d | 2016-10-19 | 2016-11-05 | PR-Z3-EW-ME-62-0020 | 30.2d | 0d |  |  | OK | 1.2.4.40 | PROC | PROC |
| PR-Z3-EW-ME-62-0040 |  | Technical Evaluation - Disconnect Switches |  | 10d | 2016-11-05 | 2016-11-16 | PR-Z3-EW-ME-62-0030 | 30.2d | 0d |  |  | OK | 1.2.4.40 | PROC | PROC |
| PR-Z3-EW-ME-62-0050 |  | PO - Disconnect Switches |  | 14d | 2016-11-16 | 2016-12-03 | PR-Z3-EW-ME-62-0040 | 30.2d | 0d |  |  | OK | 1.2.4.40 | PROC | PROC |
| PR-Z3-EW-ME-62-0060 |  | NMR 601 - Disconnect Switches |  | 6d | 2016-12-03 | 2016-12-10 | PR-Z3-EW-ME-62-0050 | 30.2d | 0d |  |  | OK | 1.2.4.40 | PROC | PROC |
| PR-Z3-EW-ME-62-0070 |  | NMR 602 - Disconnect Switches |  | 6d | 2016-12-10 | 2016-12-17 | PR-Z3-EW-ME-62-0060 | 30.2d | 0d |  |  | OK | 1.2.4.40 | PROC | PROC |
| PR-Z3-EW-ME-62-0080 |  | Start of Material Delivery - Disconnect Switches | milestone | 0d | 2017-04-03 | 2017-04-03 | PR-Z3-EW-ME-62-0070 FS+92d | 30.2d | 0d |  |  | OK | 1.2.4.40 | PROC | PROC |
| PR-Z3-EW-ME-62-0090 |  | Complete Material Delivery - Disconnect Switches |  | 15d | 2017-04-03 | 2017-04-20 | PR-Z3-EW-ME-62-0080 | 225.8d | 0d | Disconnect Switches [6 ea] | 2,967.79 | OK | 1.2.4.40 | PROC | PROC |
| PR-Z3-EW-ME-62-0100 |  | NMR 603 - Disconnect Switches |  | 10d | 2017-04-20 | 2017-05-02 | PR-Z3-EW-ME-62-0090 | 225.8d | 143.6d |  |  | OK | 1.2.4.40 | PROC | PROC |
|  | 5 | **Exhaust Fan** |  |  | 2016-10-26 | 2017-05-18 |  |  |  |  |  |  |  |  |  |
| PR-Z3-EW-ME-63-0010 |  | RFQ - Exhaust Fans |  | 7d | 2016-10-26 | 2016-11-03 | PROC-GE-GE-GE-0010 FS+63.2d | 136.4d | 0d |  |  | OK | 1.2.4.40 | PROC | PROC |
| PR-Z3-EW-ME-63-0020 |  | Material Submittal - Exhaust Fans |  | 10d | 2016-11-03 | 2016-11-15 | PR-Z3-EW-ME-63-0010 | 136.4d | 0d |  |  | OK | 1.2.4.40 | PROC | PROC |
| PR-Z3-EW-ME-63-0030 |  | Material Approval - Exhaust Fans |  | 14d | 2016-11-15 | 2016-12-01 | PR-Z3-EW-ME-63-0020 | 136.4d | 0d |  |  | OK | 1.2.4.40 | PROC | PROC |
| PR-Z3-EW-ME-63-0040 |  | Technical Evaluation - Exhaust Fans |  | 10d | 2016-12-01 | 2016-12-13 | PR-Z3-EW-ME-63-0030 | 136.4d | 0d |  |  | OK | 1.2.4.40 | PROC | PROC |
| PR-Z3-EW-ME-63-0050 |  | PO - Exhaust Fans |  | 14d | 2016-12-13 | 2016-12-29 | PR-Z3-EW-ME-63-0040 | 136.4d | 0d |  |  | OK | 1.2.4.40 | PROC | PROC |
| PR-Z3-EW-ME-63-0060 |  | NMR 601 - Exhaust Fans |  | 6d | 2016-12-29 | 2017-01-05 | PR-Z3-EW-ME-63-0050 | 136.4d | 0d |  |  | OK | 1.2.4.40 | PROC | PROC |
| PR-Z3-EW-ME-63-0070 |  | NMR 602 - Exhaust Fans |  | 6d | 2017-01-05 | 2017-01-12 | PR-Z3-EW-ME-63-0060 | 136.4d | 0d |  |  | OK | 1.2.4.40 | PROC | PROC |
| PR-Z3-EW-ME-63-0080 |  | Start of Material Delivery - Exhaust Fans | milestone | 0d | 2017-04-19 | 2017-04-19 | PR-Z3-EW-ME-63-0070 FS+83d | 136.4d | 0d |  |  | OK | 1.2.4.40 | PROC | PROC |
| PR-Z3-EW-ME-63-0090 |  | Complete Material Delivery - Exhaust Fans |  | 15d | 2017-04-19 | 2017-05-07 | PR-Z3-EW-ME-63-0080 | 211.6d | 0d | Exhaust Fan [6 ea] | 10,175.27 | OK | 1.2.4.40 | PROC | PROC |
| PR-Z3-EW-ME-63-0100 |  | NMR 603 - Exhaust Fans |  | 10d | 2017-05-07 | 2017-05-18 | PR-Z3-EW-ME-63-0090 | 211.6d | 129.4d |  |  | OK | 1.2.4.40 | PROC | PROC |

Notes:
- PR-Z3-EW-ME-61-0090: Expenses: (New Expense Item) 38510.6
- PR-Z3-EW-ME-62-0090: Expenses: (New Expense Item) 2967.79
- PR-Z3-EW-ME-63-0090: Expenses: (New Expense Item) 10175.3

| ID | WBS | Activity | Type | Duration | Start | Finish | Predecessors | Total float | Free float | Resources | Cost | Wajid | RPI_P2 - BOQ ITEMS | RPI_P2 - PROCUREMENT | RPI_P2 - PHASE |
| --- | --- | --- | --- | --- | --- | --- | --- | --- | --- | --- | --- | --- | --- | --- | --- |
|  | 6 | **Concrete Foundations including Accessories (RMU)** |  |  | 2016-11-06 | 2017-02-21 |  |  |  |  |  |  |  |  |  |
| PR-Z3-EW-ME-64-0010 |  | RFQ - Concrete Foundation (RMU) |  | 7d | 2016-11-06 | 2016-11-14 | PROC-GE-GE-GE-0010 FS+72d | 137.8d | 0d |  |  | OK | 1.2.4.40 | PROC | PROC |
| PR-Z3-EW-ME-64-0020 |  | Material Submittal - Concrete Foundation (RMU) |  | 10d | 2016-11-14 | 2016-11-26 | PR-Z3-EW-ME-64-0010 | 137.8d | 0d |  |  | OK | 1.2.4.40 | PROC | PROC |
| PR-Z3-EW-ME-64-0030 |  | Material Approval - Concrete Foundation (RMU) |  | 14d | 2016-11-26 | 2016-12-12 | PR-Z3-EW-ME-64-0020 | 137.8d | 0d |  |  | OK | 1.2.4.40 | PROC | PROC |
| PR-Z3-EW-ME-64-0040 |  | Technical Evaluation - Concrete Foundation (RMU) |  | 10d | 2016-12-12 | 2016-12-24 | PR-Z3-EW-ME-64-0030 | 137.8d | 0d |  |  | OK | 1.2.4.40 | PROC | PROC |
| PR-Z3-EW-ME-64-0050 |  | PO - Concrete Foundation (RMU) |  | 14d | 2016-12-24 | 2017-01-09 | PR-Z3-EW-ME-64-0040 | 137.8d | 0d |  |  | OK | 1.2.4.40 | PROC | PROC |
| PR-Z3-EW-ME-64-0060 |  | NMR 601 - Concrete Foundation (RMU) |  | 6d | 2017-01-09 | 2017-01-16 | PR-Z3-EW-ME-64-0050 | 137.8d | 0d |  |  | OK | 1.2.4.40 | PROC | PROC |
| PR-Z3-EW-ME-64-0070 |  | NMR 602 - Concrete Foundation (RMU) |  | 6d | 2017-01-16 | 2017-01-23 | PR-Z3-EW-ME-64-0060 | 137.8d | 0d |  |  | OK | 1.2.4.40 | PROC | PROC |
| PR-Z3-EW-ME-64-0080 |  | Start of Material Delivery - Concrete Foundation (RMU) | milestone | 0d | 2017-01-23 | 2017-01-23 | PR-Z3-EW-ME-64-0070 | 137.8d | 0d |  |  | OK | 1.2.4.40 | PROC | PROC |
| PR-Z3-EW-ME-64-0090 |  | Complete Material Delivery - Concrete Foundation (RMU) |  | 15d | 2017-01-23 | 2017-02-09 | PR-Z3-EW-ME-64-0080 | 285.8d | 0d | Concrete Foundation [5 ea] | 8,733.77 | OK | 1.2.4.40 | PROC | PROC |
| PR-Z3-EW-ME-64-0100 |  | NMR 603 - Concrete Foundation (RMU) |  | 10d | 2017-02-09 | 2017-02-21 | PR-Z3-EW-ME-64-0090 | 285.8d | 203.6d |  |  | OK | 1.2.4.40 | PROC | PROC |
|  | 7 | **Lighting Fixtures** |  |  | 2016-09-19 | 2017-04-23 |  |  |  |  |  |  |  |  |  |
| PR-Z3-EW-ME-65-0010 |  | RFQ - Lighting Fixtures |  | 7d | 2016-09-19 | 2016-09-27 | PROC-GE-GE-GE-0010 FS+31.2d | 148.8d | 0d |  |  | OK | 1.2.4.40 | PROC | PROC |
| PR-Z3-EW-ME-65-0020 |  | Material Submittal - Lighting Fixtures |  | 10d | 2016-09-27 | 2016-10-09 | PR-Z3-EW-ME-65-0010 | 148.8d | 0d |  |  | OK | 1.2.4.40 | PROC | PROC |
| PR-Z3-EW-ME-65-0030 |  | Material Approval - Lighting Fixtures |  | 14d | 2016-10-09 | 2016-10-25 | PR-Z3-EW-ME-65-0020 | 148.8d | 0d |  |  | OK | 1.2.4.40 | PROC | PROC |
| PR-Z3-EW-ME-65-0040 |  | Technical Evaluation - Lighting Fixtures |  | 10d | 2016-10-25 | 2016-11-06 | PR-Z3-EW-ME-65-0030 | 148.8d | 0d |  |  | OK | 1.2.4.40 | PROC | PROC |
| PR-Z3-EW-ME-65-0050 |  | PO - Lighting Fixtures |  | 14d | 2016-11-06 | 2016-11-22 | PR-Z3-EW-ME-65-0040 | 148.8d | 0d |  |  | OK | 1.2.4.40 | PROC | PROC |
| PR-Z3-EW-ME-65-0060 |  | NMR 601 - Lighting Fixtures |  | 6d | 2016-11-22 | 2016-11-29 | PR-Z3-EW-ME-65-0050 | 148.8d | 0d |  |  | OK | 1.2.4.40 | PROC | PROC |
| PR-Z3-EW-ME-65-0070 |  | NMR 602 - Lighting Fixtures |  | 6d | 2016-11-29 | 2016-12-06 | PR-Z3-EW-ME-65-0060 | 148.8d | 0d |  |  | OK | 1.2.4.40 | PROC | PROC |
| PR-Z3-EW-ME-65-0080 |  | Start of Material Delivery - Lighting Fixtures | milestone | 0d | 2017-03-25 | 2017-03-25 | PR-Z3-EW-ME-65-0070 FS+93d | 148.8d | 0d |  |  | OK | 1.2.4.40 | PROC | PROC |
| PR-Z3-EW-ME-65-0090 |  | Complete Material Delivery - Lighting Fixtures |  | 15d | 2017-03-25 | 2017-04-11 | PR-Z3-EW-ME-65-0080 | 233.6d | 0d | Ligting Fixtures [124 ea] | 49,597.49 | OK | 1.2.4.40 | PROC | PROC |
| PR-Z3-EW-ME-65-0100 |  | NMR 603 - Lighting Fixtures |  | 10d | 2017-04-11 | 2017-04-23 | PR-Z3-EW-ME-65-0090 | 233.6d | 151.4d |  |  | OK | 1.2.4.40 | PROC | PROC |
|  | 8 | **Junction Boxes - Explosion Proof (for Lift Stations)** |  |  | 2016-09-25 | 2017-01-16 |  |  |  |  |  |  |  |  |  |
| PR-Z3-GE-GE-249-0010 |  | RFQ - Junction Boxes - Explosion Proof (for Lift Stations) |  | 5.6d | 2016-09-25 | 2016-10-01 | PROC-GE-GE-GE-0010 FS+36d | 105d | 0d |  |  | OK | 1.2.4.40 | PROC | PROC |
| PR-Z3-GE-GE-249-0020 |  | Material Submittal - Junction Boxes - Explosion Proof (for Lift Stations) |  | 8d | 2016-10-01 | 2016-10-10 | PR-Z3-GE-GE-249-0010 | 105d | 0d |  |  | OK | 1.2.4.40 | PROC | PROC |
| PR-Z3-GE-GE-249-0030 |  | Material Approval - Junction Boxes - Explosion Proof (for Lift Stations) |  | 11.2d | 2016-10-10 | 2016-10-23 | PR-Z3-GE-GE-249-0020 | 105d | 0d |  |  | OK | 1.2.4.40 | PROC | PROC |
| PR-Z3-GE-GE-249-0040 |  | Technical Evaluation - Junction Boxes - Explosion Proof (for Lift Stations) |  | 8d | 2016-10-24 | 2016-11-01 | PR-Z3-GE-GE-249-0030 | 105d | 0d |  |  | OK | 1.2.4.40 | PROC | PROC |
| PR-Z3-GE-GE-249-0050 |  | PO - Junction Boxes - Explosion Proof (for Lift Stations) |  | 11.2d | 2016-11-02 | 2016-11-15 | PR-Z3-GE-GE-249-0040 | 105d | 0d |  |  | OK | 1.2.4.40 | PROC | PROC |
| PR-Z3-GE-GE-249-0060 |  | NMR 601 - Junction Boxes - Explosion Proof (for Lift Stations) |  | 4.8d | 2016-11-15 | 2016-11-20 | PR-Z3-GE-GE-249-0050 | 105d | 0d |  |  | OK | 1.2.4.40 | PROC | PROC |
| PR-Z3-GE-GE-249-0070 |  | NMR 602 - Junction Boxes - Explosion Proof (for Lift Stations) |  | 4.8d | 2016-11-21 | 2016-11-26 | PR-Z3-GE-GE-249-0060 | 105d | 0d |  |  | OK | 1.2.4.40 | PROC | PROC |
| PR-Z3-GE-GE-249-0080 |  | Start of Material Delivery - Junction Boxes - Explosion Proof (for Lift Stations) | milestone | 0d | 2016-12-24 | 2016-12-24 | PR-Z3-GE-GE-249-0070 FS+24d | 105d | 0d |  |  | OK | 1.2.4.40 | PROC | PROC |
| PR-Z3-GE-GE-249-0090 |  | Complete Material Delivery - Junction Boxes - Explosion Proof (for Lift Stations) |  | 12d | 2016-12-24 | 2017-01-07 | PR-Z3-GE-GE-249-0080 | 316.2d | 0d | Junction Boxes - Explosion Proof (for Lift Stations) [3 ea] |  | OK | 1.2.4.40 | PROC | PROC |
| PR-Z3-GE-GE-249-0100 |  | NMR 603 - Junction Boxes - Explosion Proof (for Lift Stations) |  | 8d | 2017-01-07 | 2017-01-16 | PR-Z3-GE-GE-249-0090 | 316.2d | 234d |  |  | OK | 1.2.4.40 | PROC | PROC |

Notes:
- PR-Z3-EW-ME-64-0090: Expenses: (New Expense Item) 8733.77
- PR-Z3-EW-ME-65-0090: Expenses: (New Expense Item) 49597.5

| ID | WBS | Activity | Type | Duration | Start | Finish | Predecessors | Total float | Free float | Resources | Cost | Wajid | RPI_P2 - BOQ ITEMS | RPI_P2 - PROCUREMENT | RPI_P2 - PHASE |
| --- | --- | --- | --- | --- | --- | --- | --- | --- | --- | --- | --- | --- | --- | --- | --- |
|  | 9 | **Electrical Switches & Panel NEMA 4X (for Lift Stations)** |  |  | 2016-09-25 | 2017-01-07 |  |  |  |  |  |  |  |  |  |
| PR-Z3-GE-GE-250-0010 |  | RFQ - Electrical Switches & Panel NEMA 4X (for Lift Stations) |  | 5.6d | 2016-09-25 | 2016-10-01 | PROC-GE-GE-GE-0010 FS+36d | 195.6d | 0d |  |  | OK | 1.2.4.40 | PROC | PROC |
| PR-Z3-GE-GE-250-0020 |  | Material Submittal - Electrical Switches & Panel NEMA 4X (for Lift Stations) |  | 8d | 2016-10-01 | 2016-10-10 | PR-Z3-GE-GE-250-0010 | 195.6d | 0d |  |  | OK | 1.2.4.40 | PROC | PROC |
| PR-Z3-GE-GE-250-0030 |  | Material Approval - Electrical Switches & Panel NEMA 4X (for Lift Stations) |  | 11.2d | 2016-10-10 | 2016-10-23 | PR-Z3-GE-GE-250-0020 | 195.6d | 0d |  |  | OK | 1.2.4.40 | PROC | PROC |
| PR-Z3-GE-GE-250-0040 |  | Technical Evaluation - Electrical Switches & Panel NEMA 4X (for Lift Stations) |  | 8d | 2016-10-24 | 2016-11-01 | PR-Z3-GE-GE-250-0030 | 195.6d | 0d |  |  | OK | 1.2.4.40 | PROC | PROC |
| PR-Z3-GE-GE-250-0050 |  | PO - Junction Boxes - Electrical Switches & Panel NEMA 4X (for Lift Stations) |  | 11.2d | 2016-11-02 | 2016-11-15 | PR-Z3-GE-GE-250-0040 | 195.6d | 0d |  |  | OK | 1.2.4.40 | PROC | PROC |
| PR-Z3-GE-GE-250-0060 |  | NMR 601 - Junction Boxes - Electrical Switches & Panel NEMA 4X (for Lift Stations) |  | 4.8d | 2016-11-15 | 2016-11-20 | PR-Z3-GE-GE-250-0050 | 195.6d | 0d |  |  | OK | 1.2.4.40 | PROC | PROC |
| PR-Z3-GE-GE-250-0070 |  | NMR 602 - Junction Boxes - Electrical Switches & Panel NEMA 4X (for Lift Stations) |  | 4.8d | 2016-11-21 | 2016-11-26 | PR-Z3-GE-GE-250-0060 | 195.6d | 0d |  |  | OK | 1.2.4.40 | PROC | PROC |
| PR-Z3-GE-GE-250-0080 |  | Start of Material Delivery - Electrical Switches & Panel NEMA 4X (for Lift Stations) | milestone | 0d | 2016-12-14 | 2016-12-14 | PR-Z3-GE-GE-250-0070 FS+16d | 195.6d | 0d |  |  | OK | 1.2.4.40 | PROC | PROC |
| PR-Z3-GE-GE-250-0090 |  | Complete Material Delivery - Electrical Switches & Panel NEMA 4X (for Lift Stations) |  | 12d | 2016-12-14 | 2016-12-28 | PR-Z3-GE-GE-250-0080 | 324.2d | 0d | Electrical Switches & Panel NEMA 4X (for Lift Stations) [3 ea] |  | OK | 1.2.4.40 | PROC | PROC |
| PR-Z3-GE-GE-250-0100 |  | NMR 603 - Junction Boxes - Electrical Switches & Panel NEMA 4X (for Lift Stations) |  | 8d | 2016-12-28 | 2017-01-07 | PR-Z3-GE-GE-250-0090 | 324.2d | 242d |  |  | OK | 1.2.4.40 | PROC | PROC |
|  | 3 | **COMMUNICATION WORKS - (MATERIAL)** |  |  | 2016-08-17 | 2017-05-17 |  |  |  |  |  |  |  |  |  |
|  | 1 | **Fiber Optic and Copper Cables System** |  |  | 2016-09-18 | 2017-05-17 |  |  |  |  |  |  |  |  |  |
|  | 1 | **FOC - Fiber Optic Cables** |  |  | 2016-09-18 | 2017-04-18 |  |  |  |  |  |  |  |  |  |
| PR-Z3-CW-FO-66-0010 |  | RFQ - Fiber Optic Cables (FOC) |  | 7d | 2016-09-18 | 2016-09-26 | PROC-GE-GE-GE-0010 FS+30d | 103.8d | 0d |  |  | OK | 1.2.5.10 | PROC | PROC |
| PR-Z3-CW-FO-66-0020 |  | Material Submittal - Fiber Optic Cables (FOC) |  | 10d | 2016-09-26 | 2016-10-08 | PR-Z3-CW-FO-66-0010 | 103.8d | 0d |  |  | OK | 1.2.5.10 | PROC | PROC |
| PR-Z3-CW-FO-66-0030 |  | Material Approval - Fiber Optic Cables (FOC) |  | 14d | 2016-10-08 | 2016-10-24 | PR-Z3-CW-FO-66-0020 | 103.8d | 0d |  |  | OK | 1.2.5.10 | PROC | PROC |
| PR-Z3-CW-FO-66-0040 |  | Technical Evaluation - Fiber Optic Cables (FOC) |  | 10d | 2016-10-24 | 2016-11-05 | PR-Z3-CW-FO-66-0030 | 103.8d | 0d |  |  | OK | 1.2.5.10 | PROC | PROC |
| PR-Z3-CW-FO-66-0050 |  | PO - Fiber Optic Cables (FOC) |  | 14d | 2016-11-05 | 2016-11-21 | PR-Z3-CW-FO-66-0040 | 103.8d | 0d |  |  | OK | 1.2.5.10 | PROC | PROC |
| PR-Z3-CW-FO-66-0060 |  | NMR 601 - Fiber Optic Cables (FOC) |  | 6d | 2016-11-21 | 2016-11-28 | PR-Z3-CW-FO-66-0050 | 103.8d | 0d |  |  | OK | 1.2.5.10 | PROC | PROC |
| PR-Z3-CW-FO-66-0070 |  | NMR 602 - Fiber Optic Cables (FOC) |  | 6d | 2016-11-28 | 2016-12-05 | PR-Z3-CW-FO-66-0060 | 103.8d | 0d |  |  | OK | 1.2.5.10 | PROC | PROC |
| PR-Z3-CW-FO-66-0080 |  | Start of Material Delivery - Fiber Optic Cables (FOC) | milestone | 0d | 2017-03-20 | 2017-03-20 | PR-Z3-CW-FO-66-0070 FS+90d | 103.8d | 0d |  |  | OK | 1.2.5.10 | PROC | PROC |
| PR-Z3-CW-FO-66-0090 |  | Complete Material Delivery - Fiber Optic Cables (FOC) |  | 15d | 2017-03-20 | 2017-04-06 | PR-Z3-CW-FO-66-0080 | 103.8d | 0d | FOC - Fiber Optic Cables [7191.46 Lm] | 671,287.93 | OK | 1.2.5.10 | PROC | PROC |
| PR-Z3-CW-FO-66-0100 |  | NMR 603 - Fiber Optic Cables (FOC) |  | 10d | 2017-04-06 | 2017-04-18 | PR-Z3-CW-FO-66-0090 | 237.8d | 155.6d |  |  | OK | 1.2.5.10 | PROC | PROC |

Notes:
- PR-Z3-CW-FO-66-0090: Expenses: (New Expense Item) 671288

| ID | WBS | Activity | Type | Duration | Start | Finish | Predecessors | Total float | Free float | Resources | Cost | Wajid | RPI_P2 - BOQ ITEMS | RPI_P2 - PROCUREMENT | RPI_P2 - PHASE |
| --- | --- | --- | --- | --- | --- | --- | --- | --- | --- | --- | --- | --- | --- | --- | --- |
|  | 2 | **FOC Splices** |  |  | 2016-09-18 | 2017-05-17 |  |  |  |  |  |  |  |  |  |
| PR-Z3-CW-FO-67-0010 |  | RFQ - Fiber Optic Cables Splices |  | 7d | 2016-09-18 | 2016-09-26 | PR-Z3-CW-FO-66-0010 SS, PROC-GE-GE-GE-0010 FS+19.2d | 129.8d | 0d |  |  | OK | 1.2.5.10 | PROC | PROC |
| PR-Z3-CW-FO-67-0020 |  | Material Submittal - Fiber Optic Cables Splices |  | 10d | 2016-09-26 | 2016-10-08 | PR-Z3-CW-FO-67-0010 | 129.8d | 0d |  |  | OK | 1.2.5.10 | PROC | PROC |
| PR-Z3-CW-FO-67-0030 |  | Material Approval - Fiber Optic Cables Splices |  | 14d | 2016-10-08 | 2016-10-24 | PR-Z3-CW-FO-67-0020 | 129.8d | 0d |  |  | OK | 1.2.5.10 | PROC | PROC |
| PR-Z3-CW-FO-67-0040 |  | Technical Evaluation - Fiber Optic Cables Splices |  | 10d | 2016-10-24 | 2016-11-05 | PR-Z3-CW-FO-67-0030 | 129.8d | 0d |  |  | OK | 1.2.5.10 | PROC | PROC |
| PR-Z3-CW-FO-67-0050 |  | PO - Fiber Optic Cables Splices |  | 14d | 2016-11-05 | 2016-11-21 | PR-Z3-CW-FO-67-0040 | 129.8d | 0d |  |  | OK | 1.2.5.10 | PROC | PROC |
| PR-Z3-CW-FO-67-0060 |  | NMR 601 - Fiber Optic Cables Splices |  | 6d | 2016-11-21 | 2016-11-28 | PR-Z3-CW-FO-67-0050 | 129.8d | 0d |  |  | OK | 1.2.5.10 | PROC | PROC |
| PR-Z3-CW-FO-67-0070 |  | NMR 602 - Fiber Optic Cables Splices |  | 6d | 2016-11-28 | 2016-12-05 | PR-Z3-CW-FO-67-0060 | 129.8d | 0d |  |  | OK | 1.2.5.10 | PROC | PROC |
| PR-Z3-CW-FO-67-0080 |  | Start of Material Delivery - Fiber Optic Cables Splices | milestone | 0d | 2017-04-18 | 2017-04-18 | PR-Z3-CW-FO-67-0070 FS+115d | 129.8d | 0d |  |  | OK | 1.2.5.10 | PROC | PROC |
| PR-Z3-CW-FO-67-0090 |  | Complete Material Delivery - Fiber Optic Cables Splices |  | 15d | 2017-04-18 | 2017-05-06 | PR-Z3-CW-FO-67-0080 | 212.8d | 0d | Splicing FOC [12 ea] | 102,930.09 | OK | 1.2.5.10 | PROC | PROC |
| PR-Z3-CW-FO-67-0100 |  | NMR 603 - Fiber Optic Cables Splices |  | 10d | 2017-05-06 | 2017-05-17 | PR-Z3-CW-FO-67-0090 | 212.8d | 130.6d |  |  | OK | 1.2.5.10 | PROC | PROC |
|  | 3 | **Copper Cables** |  |  | 2016-09-18 | 2017-05-17 |  |  |  |  |  |  |  |  |  |
| PR-Z3-CW-FO-68-0010 |  | RFQ - Copper Cables |  | 7d | 2016-09-18 | 2016-09-26 | PR-MT-Z1-LC-01-0010 SS, PROC-GE-GE-GE-0010 FS+19.2d | 78.8d | 0d |  |  | OK | 1.2.5.10 | PROC | PROC |
| PR-Z3-CW-FO-68-0020 |  | Material Submittal - Copper Cables |  | 10d | 2016-09-26 | 2016-10-08 | PR-Z3-CW-FO-68-0010 | 78.8d | 0d |  |  | OK | 1.2.5.10 | PROC | PROC |
| PR-Z3-CW-FO-68-0030 |  | Material Approval - Copper Cables |  | 14d | 2016-10-08 | 2016-10-24 | PR-Z3-CW-FO-68-0020 | 78.8d | 0d |  |  | OK | 1.2.5.10 | PROC | PROC |
| PR-Z3-CW-FO-68-0040 |  | Technical Evaluation - Copper Cables |  | 10d | 2016-10-24 | 2016-11-05 | PR-Z3-CW-FO-68-0030 | 78.8d | 0d |  |  | OK | 1.2.5.10 | PROC | PROC |
| PR-Z3-CW-FO-68-0050 |  | PO - Copper Cables |  | 14d | 2016-11-05 | 2016-11-21 | PR-Z3-CW-FO-68-0040 | 78.8d | 0d |  |  | OK | 1.2.5.10 | PROC | PROC |
| PR-Z3-CW-FO-68-0060 |  | NMR 601 - Copper Cables |  | 6d | 2016-11-21 | 2016-11-28 | PR-Z3-CW-FO-68-0050 | 78.8d | 0d |  |  | OK | 1.2.5.10 | PROC | PROC |
| PR-Z3-CW-FO-68-0070 |  | NMR 602 - Copper Cables |  | 6d | 2016-11-28 | 2016-12-05 | PR-Z3-CW-FO-68-0060 | 78.8d | 0d |  |  | OK | 1.2.5.10 | PROC | PROC |
| PR-Z3-CW-FO-68-0080 |  | Start of Material Delivery - Copper Cables | milestone | 0d | 2017-04-18 | 2017-04-18 | PR-Z3-CW-FO-68-0070 FS+115d | 78.8d | 0d |  |  | OK | 1.2.5.10 | PROC | PROC |
| PR-Z3-CW-FO-68-0090 |  | Complete Material Delivery - Copper Cables |  | 15d | 2017-04-18 | 2017-05-06 | PR-Z3-CW-FO-68-0080 | 78.8d | 0d | FOC - Copper Cables [486 Lm] | 6,253 | OK | 1.2.5.10 | PROC | PROC |
| PR-Z3-CW-FO-68-0100 |  | NMR 603 - Copper Cables |  | 10d | 2017-05-06 | 2017-05-17 | PR-Z3-CW-FO-68-0090 | 212.8d | 130.6d |  |  | OK | 1.2.5.10 | PROC | PROC |
|  | 4 | **Copper Splices** |  |  | 2016-09-18 | 2017-03-04 |  |  |  |  |  |  |  |  |  |
| PR-Z3-CW-FO-69-0010 |  | RFQ - Copper Splices |  | 5.6d | 2016-09-18 | 2016-09-24 | PR-MT-Z1-LC-02-0010 SS, PROC-GE-GE-GE-0010 FS+20d | 176.6d | 0d |  |  | OK | 1.2.5.10 | PROC | PROC |
| PR-Z3-CW-FO-69-0020 |  | Material Submittal - Copper Splices |  | 8d | 2016-09-24 | 2016-10-03 | PR-Z3-CW-FO-69-0010 | 176.6d | 0d |  |  | OK | 1.2.5.10 | PROC | PROC |
| PR-Z3-CW-FO-69-0030 |  | Material Approval - Copper Splices |  | 11.2d | 2016-10-03 | 2016-10-16 | PR-Z3-CW-FO-69-0020 | 176.6d | 0d |  |  | OK | 1.2.5.10 | PROC | PROC |
| PR-Z3-CW-FO-69-0040 |  | Technical Evaluation - Copper Splices |  | 8d | 2016-10-17 | 2016-10-25 | PR-Z3-CW-FO-69-0030 | 176.6d | 0d |  |  | OK | 1.2.5.10 | PROC | PROC |
| PR-Z3-CW-FO-69-0050 |  | PO - Copper Splices |  | 11.2d | 2016-10-26 | 2016-11-08 | PR-Z3-CW-FO-69-0040 | 176.6d | 0d |  |  | OK | 1.2.5.10 | PROC | PROC |
| PR-Z3-CW-FO-69-0060 |  | NMR 601 - Copper Splices |  | 4.8d | 2016-11-08 | 2016-11-13 | PR-Z3-CW-FO-69-0050 | 176.6d | 0d |  |  | OK | 1.2.5.10 | PROC | PROC |
| PR-Z3-CW-FO-69-0070 |  | NMR 602 - Copper Splices |  | 4.8d | 2016-11-14 | 2016-11-19 | PR-Z3-CW-FO-69-0060 | 176.6d | 0d |  |  | OK | 1.2.5.10 | PROC | PROC |
| PR-Z3-CW-FO-69-0080 |  | Start of Material Delivery - Copper Splices | milestone | 0d | 2017-02-08 | 2017-02-08 | PR-Z3-CW-FO-69-0070 FS+69.6d | 176.6d | 0d |  |  | OK | 1.2.5.10 | PROC | PROC |
| PR-Z3-CW-FO-69-0090 |  | Complete Material Delivery - Copper Splices |  | 12d | 2017-02-08 | 2017-02-22 | PR-Z3-CW-FO-69-0080 | 176.6d | 0d | Copper Splices [21 ea] | 252,071.49 | OK | 1.2.5.10 | PROC | PROC |
| PR-Z3-CW-FO-69-0100 |  | NMR 603 - Copper Splices |  | 8d | 2017-02-22 | 2017-03-04 | PR-Z3-CW-FO-69-0090 | 276.6d | 194.4d |  |  | OK | 1.2.5.10 | PROC | PROC |

Notes:
- PR-Z3-CW-FO-67-0090: Expenses: (New Expense Item) 102930
- PR-Z3-CW-FO-68-0090: Expenses: (New Expense Item) 6253
- PR-Z3-CW-FO-69-0090: Expenses: (New Expense Item) 252071

| ID | WBS | Activity | Type | Duration | Start | Finish | Predecessors | Total float | Free float | Resources | Cost | Wajid | RPI_P2 - BOQ ITEMS | RPI_P2 - PROCUREMENT | RPI_P2 - PHASE |
| --- | --- | --- | --- | --- | --- | --- | --- | --- | --- | --- | --- | --- | --- | --- | --- |
|  | 2 | **Communication and Security Systems** |  |  | 2016-08-17 | 2017-04-16 |  |  |  |  |  |  |  |  |  |
|  | 1 | **Coaxial Cable** |  |  | 2016-10-08 | 2017-02-12 |  |  |  |  |  |  |  |  |  |
| PR-Z3-CW-CS-70-0010 |  | RFQ - Coaxial Cable |  | 5.6d | 2016-10-08 | 2016-10-13 | PROC-GE-GE-GE-0010 FS+47.2d, PR-MT-Z1-LC-03-0010 SS | 157d | 0d |  |  | OK | 1.2.5.20 | PROC | PROC |
| PR-Z3-CW-CS-70-0020 |  | Material Submittal - Coaxial Cable |  | 8d | 2016-10-15 | 2016-10-23 | PR-Z3-CW-CS-70-0010 | 157d | 0d |  |  | OK | 1.2.5.20 | PROC | PROC |
| PR-Z3-CW-CS-70-0030 |  | Material Approval - Coaxial Cable |  | 11.2d | 2016-10-24 | 2016-11-06 | PR-Z3-CW-CS-70-0020 | 157d | 0d |  |  | OK | 1.2.5.20 | PROC | PROC |
| PR-Z3-CW-CS-70-0040 |  | Technical Evaluation - Coaxial Cable |  | 8d | 2016-11-06 | 2016-11-15 | PR-Z3-CW-CS-70-0030 | 157d | 0d |  |  | OK | 1.2.5.20 | PROC | PROC |
| PR-Z3-CW-CS-70-0050 |  | PO - Coaxial Cable |  | 11.2d | 2016-11-15 | 2016-11-28 | PR-Z3-CW-CS-70-0040 | 157d | 0d |  |  | OK | 1.2.5.20 | PROC | PROC |
| PR-Z3-CW-CS-70-0060 |  | NMR 601 - Coaxial Cable |  | 4.8d | 2016-11-28 | 2016-12-04 | PR-Z3-CW-CS-70-0050 | 157d | 0d |  |  | OK | 1.2.5.20 | PROC | PROC |
| PR-Z3-CW-CS-70-0070 |  | NMR 602 - Coaxial Cable |  | 4.8d | 2016-12-04 | 2016-12-08 | PR-Z3-CW-CS-70-0060 | 157d | 0d |  |  | OK | 1.2.5.20 | PROC | PROC |
| PR-Z3-CW-CS-70-0080 |  | Start of Material Delivery - Coaxial Cable | milestone | 0d | 2017-01-21 | 2017-01-21 | PR-Z3-CW-CS-70-0070 FS+36d | 157d | 0d |  |  | OK | 1.2.5.20 | PROC | PROC |
| PR-Z3-CW-CS-70-0090 |  | Complete Material Delivery - Coaxial Cable |  | 12d | 2017-01-21 | 2017-02-02 | PR-Z3-CW-CS-70-0080 | 157d | 0d | Co-Axial Cables [1020 Lm] | 51,104.96 | OK | 1.2.5.20 | PROC | PROC |
| PR-Z3-CW-CS-70-0100 |  | NMR 603 - Coaxial Cable |  | 8d | 2017-02-04 | 2017-02-12 | PR-Z3-CW-CS-70-0090 | 293d | 210.8d |  |  | OK | 1.2.5.20 | PROC | PROC |
|  | 2 | **Copper Control Cables** |  |  | 2016-10-08 | 2017-02-12 |  |  |  |  |  |  |  |  |  |
| PR-Z3-CW-CS-71-0010 |  | RFQ - Copper Control Cables |  | 5.6d | 2016-10-08 | 2016-10-13 | PROC-GE-GE-GE-0010 FS+47.2d, PR-MT-Z1-LC-04-0010 SS | 157d | 0d |  |  | OK | 1.2.5.20 | PROC | PROC |
| PR-Z3-CW-CS-71-0020 |  | Material Submittal - Copper Control Cables |  | 8d | 2016-10-15 | 2016-10-23 | PR-Z3-CW-CS-71-0010 | 157d | 0d |  |  | OK | 1.2.5.20 | PROC | PROC |
| PR-Z3-CW-CS-71-0030 |  | Material Approval - Copper Control Cables |  | 11.2d | 2016-10-24 | 2016-11-06 | PR-Z3-CW-CS-71-0020 | 157d | 0d |  |  | OK | 1.2.5.20 | PROC | PROC |
| PR-Z3-CW-CS-71-0040 |  | Technical Evaluation - Copper Control Cables |  | 8d | 2016-11-06 | 2016-11-15 | PR-Z3-CW-CS-71-0030 | 157d | 0d |  |  | OK | 1.2.5.20 | PROC | PROC |
| PR-Z3-CW-CS-71-0050 |  | PO - Copper Control Cables |  | 11.2d | 2016-11-15 | 2016-11-28 | PR-Z3-CW-CS-71-0040 | 157d | 0d |  |  | OK | 1.2.5.20 | PROC | PROC |
| PR-Z3-CW-CS-71-0060 |  | NMR 601 - Copper Control Cables |  | 4.8d | 2016-11-28 | 2016-12-04 | PR-Z3-CW-CS-71-0050 | 157d | 0d |  |  | OK | 1.2.5.20 | PROC | PROC |
| PR-Z3-CW-CS-71-0070 |  | NMR 602 - Copper Control Cables |  | 4.8d | 2016-12-04 | 2016-12-08 | PR-Z3-CW-CS-71-0060 | 157d | 0d |  |  | OK | 1.2.5.20 | PROC | PROC |
| PR-Z3-CW-CS-71-0080 |  | Start of Material Delivery - Copper Control Cables | milestone | 0d | 2017-01-21 | 2017-01-21 | PR-Z3-CW-CS-71-0070 FS+36d | 157d | 0d |  |  | OK | 1.2.5.20 | PROC | PROC |
| PR-Z3-CW-CS-71-0090 |  | Complete Material Delivery - Copper Control Cables |  | 12d | 2017-01-21 | 2017-02-02 | PR-Z3-CW-CS-71-0080 | 157d | 0d | FOC - Copper Cables [120 Lm] | 50,904.54 | OK | 1.2.5.20 | PROC | PROC |
| PR-Z3-CW-CS-71-0100 |  | NMR 603 - Copper Control Cables |  | 8d | 2017-02-04 | 2017-02-12 | PR-Z3-CW-CS-71-0090 | 293d | 210.8d |  |  | OK | 1.2.5.20 | PROC | PROC |
|  | 3 | **Splicing FOC** |  |  | 2016-10-08 | 2017-03-23 |  |  |  |  |  |  |  |  |  |
| PR-Z3-CW-CS-72-0010 |  | RFQ - Splicing FOC |  | 5.6d | 2016-10-08 | 2016-10-13 | PR-MT-Z1-LC-05-0010 SS, PROC-GE-GE-GE-0010 FS+20d | 159.4d | 0d |  |  | OK | 1.2.5.20 | PROC | PROC |
| PR-Z3-CW-CS-72-0020 |  | Material Submittal - Splicing FOC |  | 8d | 2016-10-15 | 2016-10-23 | PR-Z3-CW-CS-72-0010 | 159.4d | 0d |  |  | OK | 1.2.5.20 | PROC | PROC |
| PR-Z3-CW-CS-72-0030 |  | Material Approval - Splicing FOC |  | 11.2d | 2016-10-24 | 2016-11-06 | PR-Z3-CW-CS-72-0020 | 159.4d | 0d |  |  | OK | 1.2.5.20 | PROC | PROC |
| PR-Z3-CW-CS-72-0040 |  | Technical Evaluation - Splicing FOC |  | 8d | 2016-11-06 | 2016-11-15 | PR-Z3-CW-CS-72-0030 | 159.4d | 0d |  |  | OK | 1.2.5.20 | PROC | PROC |
| PR-Z3-CW-CS-72-0050 |  | PO - Splicing FOC |  | 11.2d | 2016-11-15 | 2016-11-28 | PR-Z3-CW-CS-72-0040 | 159.4d | 0d |  |  | OK | 1.2.5.20 | PROC | PROC |
| PR-Z3-CW-CS-72-0060 |  | NMR 601 - Splicing FOC |  | 4.8d | 2016-11-28 | 2016-12-04 | PR-Z3-CW-CS-72-0050 | 159.4d | 0d |  |  | OK | 1.2.5.20 | PROC | PROC |
| PR-Z3-CW-CS-72-0070 |  | NMR 602 - Splicing FOC |  | 4.8d | 2016-12-04 | 2016-12-08 | PR-Z3-CW-CS-72-0060 | 159.4d | 0d |  |  | OK | 1.2.5.20 | PROC | PROC |
| PR-Z3-CW-CS-72-0080 |  | Start of Material Delivery - Splicing FOC | milestone | 0d | 2017-02-28 | 2017-02-28 | PR-Z3-CW-CS-72-0070 FS+69.6d | 159.4d | 0d |  |  | OK | 1.2.5.20 | PROC | PROC |
| PR-Z3-CW-CS-72-0090 |  | Complete Material Delivery - Splicing FOC |  | 12d | 2017-02-28 | 2017-03-14 | PR-Z3-CW-CS-72-0080 | 159.4d | 0d | Splicing FOC [22 ea] | 269,754 | OK | 1.2.5.20 | PROC | PROC |
| PR-Z3-CW-CS-72-0100 |  | NMR 603 - Splicing FOC |  | 8d | 2017-03-14 | 2017-03-23 | PR-Z3-CW-CS-72-0090 | 259.4d | 177.2d |  |  | OK | 1.2.5.20 | PROC | PROC |

Notes:
- PR-Z3-CW-CS-70-0090: Expenses: (New Expense Item) 51105
- PR-Z3-CW-CS-71-0090: Expenses: (New Expense Item) 50904.5
- PR-Z3-CW-CS-72-0090: Expenses: (New Expense Item) 269754

| ID | WBS | Activity | Type | Duration | Start | Finish | Predecessors | Total float | Free float | Resources | Cost | Wajid | RPI_P2 - BOQ ITEMS | RPI_P2 - PROCUREMENT | RPI_P2 - PHASE |
| --- | --- | --- | --- | --- | --- | --- | --- | --- | --- | --- | --- | --- | --- | --- | --- |
|  | 4 | **Sand for Backfilling** |  |  | 2016-08-17 | 2017-03-15 |  |  |  |  |  |  |  |  |  |
| PR-Z3-CW-CS-73-0010 |  | RFQ - Sand for Backfilling |  | 5.6d | 2016-08-17 | 2016-08-23 | PROC-GE-GE-GE-0010, PR-MT-Z1-LC-08-0010 SS | 266.8d | 0d |  |  | OK | 1.2.5.20 | PROC | PROC |
| PR-Z3-CW-CS-73-0020 |  | Material Submittal - Sand for Backfilling |  | 8d | 2016-08-23 | 2016-09-01 | PR-Z3-CW-CS-73-0010 | 266.8d | 0d |  |  | OK | 1.2.5.20 | PROC | PROC |
| PR-Z3-CW-CS-73-0030 |  | Material Approval - Sand for Backfilling |  | 11.2d | 2016-09-01 | 2016-09-19 | PR-Z3-CW-CS-73-0020 | 266.8d | 0d |  |  | OK | 1.2.5.20 | PROC | PROC |
| PR-Z3-CW-CS-73-0040 |  | Technical Evaluation - Sand for Backfilling |  | 8d | 2016-09-20 | 2016-09-28 | PR-Z3-CW-CS-73-0030 | 266.8d | 0d |  |  | OK | 1.2.5.20 | PROC | PROC |
| PR-Z3-CW-CS-73-0050 |  | PO - Sand for Backfilling |  | 11.2d | 2016-09-29 | 2016-10-12 | PR-Z3-CW-CS-73-0040 | 266.8d | 0d |  |  | OK | 1.2.5.20 | PROC | PROC |
| PR-Z3-CW-CS-73-0060 |  | NMR 601 - Sand for Backfilling |  | 4.8d | 2016-10-12 | 2016-10-17 | PR-Z3-CW-CS-73-0050 | 266.8d | 0d |  |  | OK | 1.2.5.20 | PROC | PROC |
| PR-Z3-CW-CS-73-0070 |  | NMR 602 - Sand for Backfilling |  | 4.8d | 2016-10-18 | 2016-10-23 | PR-Z3-CW-CS-73-0060 | 266.8d | 0d |  |  | OK | 1.2.5.20 | PROC | PROC |
| PR-Z3-CW-CS-73-0080 |  | Start of Material Delivery - Sand for Backfilling | milestone | 0d | 2016-10-26 | 2016-10-26 | PR-Z3-CW-CS-73-0070 FS+2.4d | 266.8d | 0d |  |  | OK | 1.2.5.20 | PROC | PROC |
| PR-Z3-CW-CS-73-0090 |  | Complete Material Delivery - Sand for Backfilling |  | 120d | 2016-10-26 | 2017-03-15 | PR-Z3-CW-CS-73-0080 | 266.8d | 184.6d | Sand for Backfilling [1434.11 Cum] | 137,957.41 | OK | 1.2.5.20 | PROC | PROC |
|  | 5 | **Warning Tapes** |  |  | 2016-08-28 | 2017-04-06 |  |  |  |  |  |  |  |  |  |
| PR-Z3-CW-CS-74-0010 |  | RFQ - Warning Tapes |  | 5.6d | 2016-08-28 | 2016-09-03 | PROC-GE-GE-GE-0010 FS+15.2d, PR-MT-Z1-LC-09-0010 SS | 247.4d | 0d |  |  | OK | 1.2.5.20 | PROC | PROC |
| PR-Z3-CW-CS-74-0020 |  | Material Submittal - Warning Tapes |  | 8d | 2016-09-03 | 2016-09-17 | PR-Z3-CW-CS-74-0010 | 247.4d | 0d |  |  | OK | 1.2.5.20 | PROC | PROC |
| PR-Z3-CW-CS-74-0030 |  | Material Approval - Warning Tapes |  | 11.2d | 2016-09-17 | 2016-09-29 | PR-Z3-CW-CS-74-0020 | 247.4d | 0d |  |  | OK | 1.2.5.20 | PROC | PROC |
| PR-Z3-CW-CS-74-0040 |  | Technical Evaluation - Warning Tapes |  | 8d | 2016-10-01 | 2016-10-09 | PR-Z3-CW-CS-74-0030 | 247.4d | 0d |  |  | OK | 1.2.5.20 | PROC | PROC |
| PR-Z3-CW-CS-74-0050 |  | PO - Warning Tapes |  | 11.2d | 2016-10-10 | 2016-10-23 | PR-Z3-CW-CS-74-0040 | 247.4d | 0d |  |  | OK | 1.2.5.20 | PROC | PROC |
| PR-Z3-CW-CS-74-0060 |  | NMR 601 - Warning Tapes |  | 4.8d | 2016-10-23 | 2016-10-27 | PR-Z3-CW-CS-74-0050 | 247.4d | 0d |  |  | OK | 1.2.5.20 | PROC | PROC |
| PR-Z3-CW-CS-74-0070 |  | NMR 602 - Warning Tapes |  | 4.8d | 2016-10-29 | 2016-11-02 | PR-Z3-CW-CS-74-0060 | 247.4d | 0d |  |  | OK | 1.2.5.20 | PROC | PROC |
| PR-Z3-CW-CS-74-0080 |  | Start of Material Delivery - Warning Tapes | milestone | 0d | 2016-11-08 | 2016-11-08 | PR-Z3-CW-CS-74-0070 FS+4.8d | 247.4d | 0d |  |  | OK | 1.2.5.20 | PROC | PROC |
| PR-Z3-CW-CS-74-0090 |  | Complete Material Delivery - Warning Tapes |  | 120d | 2016-11-08 | 2017-03-28 | PR-Z3-CW-CS-74-0080 | 247.4d | 0d | Warning Tapes [17926 Lm] | 89,814.45 | OK | 1.2.5.20 | PROC | PROC |
| PR-Z3-CW-CS-74-0100 |  | NMR 603 - Warning Tapes |  | 8d | 2017-03-28 | 2017-04-06 | PR-Z3-CW-CS-74-0090 | 247.4d | 165.2d |  |  | OK | 1.2.5.20 | PROC | PROC |
|  | 6 | **Red Tiles** |  |  | 2016-09-01 | 2017-04-11 |  |  |  |  |  |  |  |  |  |
| PR-Z3-CW-CS-75-0010 |  | RFQ - Red Tiles |  | 5.6d | 2016-09-01 | 2016-09-07 | PR-MT-Z1-LC-10-0010 SS, PROC-GE-GE-GE-0010 FS+15.2d | 243.4d | 0d |  |  | OK | 1.2.5.20 | PROC | PROC |
| PR-Z3-CW-CS-75-0020 |  | Material Submittal - Red Tiles |  | 8d | 2016-09-07 | 2016-09-21 | PR-Z3-CW-CS-75-0010 | 243.4d | 0d |  |  | OK | 1.2.5.20 | PROC | PROC |
| PR-Z3-CW-CS-75-0030 |  | Material Approval - Red Tiles |  | 11.2d | 2016-09-21 | 2016-10-04 | PR-Z3-CW-CS-75-0020 | 243.4d | 0d |  |  | OK | 1.2.5.20 | PROC | PROC |
| PR-Z3-CW-CS-75-0040 |  | Technical Evaluation - Red Tiles |  | 8d | 2016-10-05 | 2016-10-13 | PR-Z3-CW-CS-75-0030 | 243.4d | 0d |  |  | OK | 1.2.5.20 | PROC | PROC |
| PR-Z3-CW-CS-75-0050 |  | PO - Red Tiles |  | 11.2d | 2016-10-15 | 2016-10-27 | PR-Z3-CW-CS-75-0040 | 243.4d | 0d |  |  | OK | 1.2.5.20 | PROC | PROC |
| PR-Z3-CW-CS-75-0060 |  | NMR 601 - Red Tiles |  | 4.8d | 2016-10-27 | 2016-11-01 | PR-Z3-CW-CS-75-0050 | 243.4d | 0d |  |  | OK | 1.2.5.20 | PROC | PROC |
| PR-Z3-CW-CS-75-0070 |  | NMR 602 - Red Tiles |  | 4.8d | 2016-11-02 | 2016-11-07 | PR-Z3-CW-CS-75-0060 | 243.4d | 0d |  |  | OK | 1.2.5.20 | PROC | PROC |
| PR-Z3-CW-CS-75-0080 |  | Start of Material Delivery - Red Tiles | milestone | 0d | 2016-11-13 | 2016-11-13 | PR-Z3-CW-CS-75-0070 FS+4.8d | 243.4d | 0d |  |  | OK | 1.2.5.20 | PROC | PROC |
| PR-Z3-CW-CS-75-0090 |  | Complete Material Delivery - Red Tiles |  | 120d | 2016-11-13 | 2017-04-02 | PR-Z3-CW-CS-75-0080 | 243.4d | 0d | Red Tiles [89630 ea] | 449,072.27 | OK | 1.2.5.20 | PROC | PROC |
| PR-Z3-CW-CS-75-0100 |  | NMR 603 - Red Tiles |  | 8d | 2017-04-02 | 2017-04-11 | PR-Z3-CW-CS-75-0090 | 243.4d | 161.2d |  |  | OK | 1.2.5.20 | PROC | PROC |

Notes:
- PR-Z3-CW-CS-73-0090: Expenses: (New Expense Item) 137957
- PR-Z3-CW-CS-74-0090: Expenses: (New Expense Item) 89814.4
- PR-Z3-CW-CS-75-0090: Expenses: (New Expense Item) 449072

| ID | WBS | Activity | Type | Duration | Start | Finish | Predecessors | Total float | Free float | Resources | Cost | Wajid | RPI_P2 - BOQ ITEMS | RPI_P2 - PROCUREMENT | RPI_P2 - PHASE |
| --- | --- | --- | --- | --- | --- | --- | --- | --- | --- | --- | --- | --- | --- | --- | --- |
|  | 7 | **UTP Cables** |  |  | 2016-09-24 | 2017-03-07 |  |  |  |  |  |  |  |  |  |
| PR-Z3-CW-CS-76-0010 |  | RFQ - UTP Cables |  | 5.6d | 2016-09-24 | 2016-09-29 | PROC-GE-GE-GE-0010 FS+35d | 273.2d | 0d |  |  | OK | 1.2.5.20 | PROC | PROC |
| PR-Z3-CW-CS-76-0020 |  | Material Submittal - UTP Cables |  | 8d | 2016-09-29 | 2016-10-09 | PR-Z3-CW-CS-76-0010 | 273.2d | 0d |  |  | OK | 1.2.5.20 | PROC | PROC |
| PR-Z3-CW-CS-76-0030 |  | Material Approval - UTP Cables |  | 11.2d | 2016-10-09 | 2016-10-22 | PR-Z3-CW-CS-76-0020 | 273.2d | 0d |  |  | OK | 1.2.5.20 | PROC | PROC |
| PR-Z3-CW-CS-76-0040 |  | Technical Evaluation - UTP Cables |  | 8d | 2016-10-23 | 2016-10-31 | PR-Z3-CW-CS-76-0030 | 273.2d | 0d |  |  | OK | 1.2.5.20 | PROC | PROC |
| PR-Z3-CW-CS-76-0050 |  | PO - UTP Cables |  | 11.2d | 2016-11-01 | 2016-11-14 | PR-Z3-CW-CS-76-0040 | 273.2d | 0d |  |  | OK | 1.2.5.20 | PROC | PROC |
| PR-Z3-CW-CS-76-0060 |  | NMR 601 - UTP Cables |  | 4.8d | 2016-11-14 | 2016-11-19 | PR-Z3-CW-CS-76-0050 | 273.2d | 0d |  |  | OK | 1.2.5.20 | PROC | PROC |
| PR-Z3-CW-CS-76-0070 |  | NMR 602 - UTP Cables |  | 4.8d | 2016-11-20 | 2016-11-24 | PR-Z3-CW-CS-76-0060 | 273.2d | 0d |  |  | OK | 1.2.5.20 | PROC | PROC |
| PR-Z3-CW-CS-76-0080 |  | Start of Material Delivery - UTP Cables | milestone | 0d | 2017-02-12 | 2017-02-12 | PR-Z3-CW-CS-76-0070 FS+68d | 273.2d | 0d |  |  | OK | 1.2.5.20 | PROC | PROC |
| PR-Z3-CW-CS-76-0090 |  | Complete Material Delivery - UTP Cables |  | 12d | 2017-02-12 | 2017-02-26 | PR-Z3-CW-CS-76-0080 | 273.2d | 0d | UTP Cables [1 Lm] | 6,012.35 | OK | 1.2.5.20 | PROC | PROC |
| PR-Z3-CW-CS-76-0100 |  | NMR 603 - UTP Cables |  | 8d | 2017-02-26 | 2017-03-07 | PR-Z3-CW-CS-76-0090 | 273.2d | 191d |  |  | OK | 1.2.5.20 | PROC | PROC |
|  | 8 | **Data Cabinet with Components (for Snack Booths)** |  |  | 2016-10-16 | 2017-03-11 |  |  |  |  |  |  |  |  |  |
| PR-Z3-CW-CS-77-0010 |  | RFQ - Data Cabiet with Components (for Snack Booths) |  | 5.6d | 2016-10-16 | 2016-10-23 | PROC-GE-GE-GE-0010 FS+54.4d | 34.6d | 0d |  |  | OK | 1.2.5.20 | PROC | PROC |
| PR-Z3-CW-CS-77-0020 |  | Material Submittal - Data Cabiet with Components (for Snack Booths) |  | 8d | 2016-10-23 | 2016-11-01 | PR-Z3-CW-CS-77-0010 | 34.6d | 0d |  |  | OK | 1.2.5.20 | PROC | PROC |
| PR-Z3-CW-CS-77-0030 |  | Material Approval - Data Cabiet with Components (for Snack Booths) |  | 11.2d | 2016-11-01 | 2016-11-14 | PR-Z3-CW-CS-77-0020 | 34.6d | 0d |  |  | OK | 1.2.5.20 | PROC | PROC |
| PR-Z3-CW-CS-77-0040 |  | Technical Evaluation - Data Cabiet with Components (for Snack Booths) |  | 8d | 2016-11-14 | 2016-11-23 | PR-Z3-CW-CS-77-0030 | 34.6d | 0d |  |  | OK | 1.2.5.20 | PROC | PROC |
| PR-Z3-CW-CS-77-0050 |  | PO - Data Cabiet with Components (for Snack Booths) |  | 11.2d | 2016-11-23 | 2016-12-06 | PR-Z3-CW-CS-77-0040 | 34.6d | 0d |  |  | OK | 1.2.5.20 | PROC | PROC |
| PR-Z3-CW-CS-77-0060 |  | NMR 601 - Data Cabiet with Components (for Snack Booths) |  | 4.8d | 2016-12-06 | 2016-12-12 | PR-Z3-CW-CS-77-0050 | 34.6d | 0d |  |  | OK | 1.2.5.20 | PROC | PROC |
| PR-Z3-CW-CS-77-0070 |  | NMR 602 - Data Cabiet with Components (for Snack Booths) |  | 4.8d | 2016-12-12 | 2016-12-18 | PR-Z3-CW-CS-77-0060 | 34.6d | 0d |  |  | OK | 1.2.5.20 | PROC | PROC |
| PR-Z3-CW-CS-77-0080 |  | Start of Material Delivery - Data Cabiet with Components (for Snack Booths) | milestone | 0d | 2017-02-15 | 2017-02-15 | PR-Z3-CW-CS-77-0070 FS+51.2d | 34.6d | 0d |  |  | OK | 1.2.5.20 | PROC | PROC |
| PR-Z3-CW-CS-77-0090 |  | Complete Material Delivery - Data Cabiet with Components (for Snack Booths) |  | 12d | 2017-02-15 | 2017-03-01 | PR-Z3-CW-CS-77-0080 | 34.6d | 0d | Data Cabinet with Components [4 ea] | 292,600.92 | OK | 1.2.5.20 | PROC | PROC |
| PR-Z3-CW-CS-77-0100 |  | NMR 603 - Data Cabiet with Components (for Snack Booths) |  | 8d | 2017-03-01 | 2017-03-11 | PR-Z3-CW-CS-77-0090 | 270.6d | 188.4d |  |  | OK | 1.2.5.20 | PROC | PROC |
|  | 9 | **Telecom Enclosure (for Snack Booths)** |  |  | 2016-10-16 | 2017-03-11 |  |  |  |  |  |  |  |  |  |
| PR-Z3-CW-CS-78-0010 |  | RFQ - Telecom Enclosure (for Snack Booths) |  | 5.6d | 2016-10-16 | 2016-10-23 | PROC-GE-GE-GE-0010 FS+54.4d | 100.6d | 0d |  |  | OK | 1.2.5.20 | PROC | PROC |
| PR-Z3-CW-CS-78-0020 |  | Material Submittal - Telecom Enclosure (for Snack Booths) |  | 8d | 2016-10-23 | 2016-11-01 | PR-Z3-CW-CS-78-0010 | 100.6d | 0d |  |  | OK | 1.2.5.20 | PROC | PROC |
| PR-Z3-CW-CS-78-0030 |  | Material Approval - Telecom Enclosure (for Snack Booths) |  | 11.2d | 2016-11-01 | 2016-11-14 | PR-Z3-CW-CS-78-0020 | 100.6d | 0d |  |  | OK | 1.2.5.20 | PROC | PROC |
| PR-Z3-CW-CS-78-0040 |  | Technical Evaluation - Telecom Enclosure (for Snack Booths) |  | 8d | 2016-11-14 | 2016-11-23 | PR-Z3-CW-CS-78-0030 | 100.6d | 0d |  |  | OK | 1.2.5.20 | PROC | PROC |
| PR-Z3-CW-CS-78-0050 |  | PO - Telecom Enclosure (for Snack Booths) |  | 11.2d | 2016-11-23 | 2016-12-06 | PR-Z3-CW-CS-78-0040 | 100.6d | 0d |  |  | OK | 1.2.5.20 | PROC | PROC |
| PR-Z3-CW-CS-78-0060 |  | NMR 601 - Telecom Enclosure (for Snack Booths) |  | 4.8d | 2016-12-06 | 2016-12-12 | PR-Z3-CW-CS-78-0050 | 100.6d | 0d |  |  | OK | 1.2.5.20 | PROC | PROC |
| PR-Z3-CW-CS-78-0070 |  | NMR 602 - Telecom Enclosure (for Snack Booths) |  | 4.8d | 2016-12-12 | 2016-12-18 | PR-Z3-CW-CS-78-0060 | 100.6d | 0d |  |  | OK | 1.2.5.20 | PROC | PROC |
| PR-Z3-CW-CS-78-0080 |  | Start of Material Delivery - Telecom Enclosure (for Snack Booths) | milestone | 0d | 2017-02-15 | 2017-02-15 | PR-Z3-CW-CS-78-0070 FS+51.2d | 100.6d | 0d |  |  | OK | 1.2.5.20 | PROC | PROC |
| PR-Z3-CW-CS-78-0090 |  | Complete Material Delivery - Telecom Enclosure (for Snack Booths) |  | 12d | 2017-02-15 | 2017-03-01 | PR-Z3-CW-CS-78-0080 | 100.6d | 0d | Telecom Enclosure [4 ea] | 48,098.78 | OK | 1.2.5.20 | PROC | PROC |
| PR-Z3-CW-CS-78-0100 |  | NMR 603 - Telecom Enclosure (for Snack Booths) |  | 8d | 2017-03-01 | 2017-03-11 | PR-Z3-CW-CS-78-0090 | 270.6d | 188.4d |  |  | OK | 1.2.5.20 | PROC | PROC |

Notes:
- PR-Z3-CW-CS-76-0090: Expenses: (New Expense Item) 6012.35
- PR-Z3-CW-CS-77-0090: Expenses: (New Expense Item) 292601
- PR-Z3-CW-CS-78-0090: Expenses: (New Expense Item) 48098.8

| ID | WBS | Activity | Type | Duration | Start | Finish | Predecessors | Total float | Free float | Resources | Cost | Wajid | RPI_P2 - BOQ ITEMS | RPI_P2 - PROCUREMENT | RPI_P2 - PHASE |
| --- | --- | --- | --- | --- | --- | --- | --- | --- | --- | --- | --- | --- | --- | --- | --- |
|  | 10 | **Telephone Outlet, Conduiting & Cabling (for Snack Booths)** |  |  | 2016-10-17 | 2017-02-21 |  |  |  |  |  |  |  |  |  |
| PR-Z3-CW-CS-79-0010 |  | RFQ - Telephone Outlet, Conduiting & Cabling (for Snack Booths) |  | 5.6d | 2016-10-17 | 2016-10-23 | PROC-GE-GE-GE-0010 FS+55d | 121.2d | 0d |  |  | OK | 1.2.5.20 | PROC | PROC |
| PR-Z3-CW-CS-79-0020 |  | Material Submittal - Telephone Outlet, Conduiting & Cabling (for Snack Booths) |  | 8d | 2016-10-23 | 2016-11-01 | PR-Z3-CW-CS-79-0010 | 121.2d | 0d |  |  | OK | 1.2.5.20 | PROC | PROC |
| PR-Z3-CW-CS-79-0030 |  | Material Approval - Telephone Outlet, Conduiting & Cabling (for Snack Booths) |  | 11.2d | 2016-11-01 | 2016-11-14 | PR-Z3-CW-CS-79-0020 | 121.2d | 0d |  |  | OK | 1.2.5.20 | PROC | PROC |
| PR-Z3-CW-CS-79-0040 |  | Technical Evaluation - Telephone Outlet, Conduiting & Cabling (for Snack Booths) |  | 8d | 2016-11-15 | 2016-11-23 | PR-Z3-CW-CS-79-0030 | 121.2d | 0d |  |  | OK | 1.2.5.20 | PROC | PROC |
| PR-Z3-CW-CS-79-0050 |  | PO - Telephone Outlet, Conduiting & Cabling (for Snack Booths) |  | 11.2d | 2016-11-24 | 2016-12-07 | PR-Z3-CW-CS-79-0040 | 121.2d | 0d |  |  | OK | 1.2.5.20 | PROC | PROC |
| PR-Z3-CW-CS-79-0060 |  | NMR 601 - Telephone Outlet, Conduiting & Cabling (for Snack Booths) |  | 4.8d | 2016-12-07 | 2016-12-12 | PR-Z3-CW-CS-79-0050 | 121.2d | 0d |  |  | OK | 1.2.5.20 | PROC | PROC |
| PR-Z3-CW-CS-79-0070 |  | NMR 602 - Telephone Outlet, Conduiting & Cabling (for Snack Booths) |  | 4.8d | 2016-12-13 | 2016-12-18 | PR-Z3-CW-CS-79-0060 | 121.2d | 0d |  |  | OK | 1.2.5.20 | PROC | PROC |
| PR-Z3-CW-CS-79-0080 |  | Start of Material Delivery - Telephone Outlet, Conduiting & Cabling (for Snack Booths) | milestone | 0d | 2017-01-29 | 2017-01-29 | PR-Z3-CW-CS-79-0070 FS+36d | 121.2d | 0d |  |  | OK | 1.2.5.20 | PROC | PROC |
| PR-Z3-CW-CS-79-0090 |  | Complete Material Delivery - Telephone Outlet, Conduiting & Cabling (for Snack Booths) |  | 12d | 2017-01-29 | 2017-02-12 | PR-Z3-CW-CS-79-0080 | 121.2d | 0d | Telephone Outlet, Conduiting, Cabling & Accessories [4 ea] | 60,123.48 | OK | 1.2.5.20 | PROC | PROC |
| PR-Z3-CW-CS-79-0100 |  | NMR 603 - Telephone Outlet, Conduiting & Cabling (for Snack Booths) |  | 8d | 2017-02-12 | 2017-02-21 | PR-Z3-CW-CS-79-0090 | 285.2d | 203d |  |  | OK | 1.2.5.20 | PROC | PROC |
|  | 11 | **FOC - Fiber Optic Cables (for Research Exchange Building)** |  |  | 2016-10-08 | 2017-03-23 |  |  |  |  |  |  |  |  |  |
| PR-Z3-CW-CS-80-0010 |  | RFQ - Fiber Optic Cables (for Research Exchange Building) |  | 5.6d | 2016-10-08 | 2016-10-13 | PROC-GE-GE-GE-0010 FS+47d | 259.6d | 0d |  |  | OK | 1.2.5.20 | PROC | PROC |
| PR-Z3-CW-CS-80-0020 |  | Material Submittal - Fiber Optic Cables (for Research Exchange Building) |  | 8d | 2016-10-13 | 2016-10-23 | PR-Z3-CW-CS-80-0010 | 259.6d | 0d |  |  | OK | 1.2.5.20 | PROC | PROC |
| PR-Z3-CW-CS-80-0030 |  | Material Approval - Fiber Optic Cables (for Research Exchange Building) |  | 11.2d | 2016-10-23 | 2016-11-05 | PR-Z3-CW-CS-80-0020 | 259.6d | 0d |  |  | OK | 1.2.5.20 | PROC | PROC |
| PR-Z3-CW-CS-80-0040 |  | Technical Evaluation - Fiber Optic Cables (for Research Exchange Building) |  | 8d | 2016-11-06 | 2016-11-14 | PR-Z3-CW-CS-80-0030 | 259.6d | 0d |  |  | OK | 1.2.5.20 | PROC | PROC |
| PR-Z3-CW-CS-80-0050 |  | PO - Fiber Optic Cables (for Research Exchange Building) |  | 11.2d | 2016-11-15 | 2016-11-28 | PR-Z3-CW-CS-80-0040 | 259.6d | 0d |  |  | OK | 1.2.5.20 | PROC | PROC |
| PR-Z3-CW-CS-80-0060 |  | NMR 601 - Fiber Optic Cables (for Research Exchange Building) |  | 4.8d | 2016-11-28 | 2016-12-03 | PR-Z3-CW-CS-80-0050 | 259.6d | 0d |  |  | OK | 1.2.5.20 | PROC | PROC |
| PR-Z3-CW-CS-80-0070 |  | NMR 602 - Fiber Optic Cables (for Research Exchange Building) |  | 4.8d | 2016-12-04 | 2016-12-08 | PR-Z3-CW-CS-80-0060 | 259.6d | 0d |  |  | OK | 1.2.5.20 | PROC | PROC |
| PR-Z3-CW-CS-80-0080 |  | Start of Material Delivery - Fiber Optic Cables (for Research Exchange Building) | milestone | 0d | 2017-02-28 | 2017-02-28 | PR-Z3-CW-CS-80-0070 FS+69.6d | 259.6d | 0d |  |  | OK | 1.2.5.20 | PROC | PROC |
| PR-Z3-CW-CS-80-0090 |  | Complete Material Delivery - Fiber Optic Cables (for Research Exchange Building) |  | 12d | 2017-02-28 | 2017-03-14 | PR-Z3-CW-CS-80-0080 | 259.6d | 0d | FOC - Fiber Optic Cables [420 Lm] | 58,921.01 | OK | 1.2.5.20 | PROC | PROC |
| PR-Z3-CW-CS-80-0100 |  | NMR 603 - Fiber Optic Cables (for Research Exchange Building) |  | 8d | 2017-03-14 | 2017-03-23 | PR-Z3-CW-CS-80-0090 | 259.6d | 177.4d |  |  | OK | 1.2.5.20 | PROC | PROC |
|  | 12 | **Splice Closure (for Research Exchange Building)** |  |  | 2016-10-17 | 2017-03-07 |  |  |  |  |  |  |  |  |  |
| PR-Z3-CW-CS-81-0010 |  | RFQ - Splice Closure (for Research Exchange Building) |  | 5.6d | 2016-10-17 | 2016-10-23 | PROC-GE-GE-GE-0010 FS+55.2d | 41d | 0d |  |  | OK | 1.2.5.20 | PROC | PROC |
| PR-Z3-CW-CS-81-0020 |  | Material Submittal - Splice Closure (for Research Exchange Building) |  | 8d | 2016-10-24 | 2016-11-01 | PR-Z3-CW-CS-81-0010 | 41d | 0d |  |  | OK | 1.2.5.20 | PROC | PROC |
| PR-Z3-CW-CS-81-0030 |  | Material Approval - Splice Closure (for Research Exchange Building) |  | 11.2d | 2016-11-02 | 2016-11-15 | PR-Z3-CW-CS-81-0020 | 41d | 0d |  |  | OK | 1.2.5.20 | PROC | PROC |
| PR-Z3-CW-CS-81-0040 |  | Technical Evaluation - Splice Closure (for Research Exchange Building) |  | 8d | 2016-11-15 | 2016-11-24 | PR-Z3-CW-CS-81-0030 | 41d | 0d |  |  | OK | 1.2.5.20 | PROC | PROC |
| PR-Z3-CW-CS-81-0050 |  | PO - Splice Closure (for Research Exchange Building) |  | 11.2d | 2016-11-24 | 2016-12-07 | PR-Z3-CW-CS-81-0040 | 41d | 0d |  |  | OK | 1.2.5.20 | PROC | PROC |
| PR-Z3-CW-CS-81-0060 |  | NMR 601 - Splice Closure (for Research Exchange Building) |  | 4.8d | 2016-12-07 | 2016-12-13 | PR-Z3-CW-CS-81-0050 | 41d | 0d |  |  | OK | 1.2.5.20 | PROC | PROC |
| PR-Z3-CW-CS-81-0070 |  | NMR 602 - Splice Closure (for Research Exchange Building) |  | 4.8d | 2016-12-13 | 2016-12-18 | PR-Z3-CW-CS-81-0060 | 41d | 0d |  |  | OK | 1.2.5.20 | PROC | PROC |
| PR-Z3-CW-CS-81-0080 |  | Start of Material Delivery - Splice Closure (for Research Exchange Building) | milestone | 0d | 2017-02-13 | 2017-02-13 | PR-Z3-CW-CS-81-0070 FS+48d | 41d | 0d |  |  | OK | 1.2.5.20 | PROC | PROC |
| PR-Z3-CW-CS-81-0090 |  | Complete Material Delivery - Splice Closure (for Research Exchange Building) |  | 12d | 2017-02-13 | 2017-02-26 | PR-Z3-CW-CS-81-0080 | 41d | 0d | Splice Closure [10 ea] | 139,887.29 | OK | 1.2.5.20 | PROC | PROC |
| PR-Z3-CW-CS-81-0100 |  | NMR 603 - Splice Closure (for Research Exchange Building) |  | 8d | 2017-02-27 | 2017-03-07 | PR-Z3-CW-CS-81-0090 | 273d | 190.8d |  |  | OK | 1.2.5.20 | PROC | PROC |

Notes:
- PR-Z3-CW-CS-79-0090: Expenses: (New Expense Item) 60123.5
- PR-Z3-CW-CS-80-0090: Expenses: (New Expense Item) 58921
- PR-Z3-CW-CS-81-0090: Expenses: (New Expense Item) 139887

| ID | WBS | Activity | Type | Duration | Start | Finish | Predecessors | Total float | Free float | Resources | Cost | Wajid | RPI_P2 - BOQ ITEMS | RPI_P2 - PROCUREMENT | RPI_P2 - PHASE |
| --- | --- | --- | --- | --- | --- | --- | --- | --- | --- | --- | --- | --- | --- | --- | --- |
|  | 13 | **Adtran 850 (for Research Exchange Building** |  |  | 2016-10-17 | 2017-03-07 |  |  |  |  |  |  |  |  |  |
| PR-Z3-CW-CS-82-0010 |  | RFQ - Adtran 850 (for Research Exchange Building) |  | 5.6d | 2016-10-17 | 2016-10-23 | PROC-GE-GE-GE-0010 FS+55.2d | 113d | 0d |  |  | OK | 1.2.5.20 | PROC | PROC |
| PR-Z3-CW-CS-82-0020 |  | Material Submittal - Adtran 850 (for Research Exchange Building) |  | 8d | 2016-10-24 | 2016-11-01 | PR-Z3-CW-CS-82-0010 | 113d | 0d |  |  | OK | 1.2.5.20 | PROC | PROC |
| PR-Z3-CW-CS-82-0030 |  | Material Approval - Adtran 850 (for Research Exchange Building) |  | 11.2d | 2016-11-02 | 2016-11-15 | PR-Z3-CW-CS-82-0020 | 113d | 0d |  |  | OK | 1.2.5.20 | PROC | PROC |
| PR-Z3-CW-CS-82-0040 |  | Technical Evaluation - Adtran 850 (for Research Exchange Building) |  | 8d | 2016-11-15 | 2016-11-24 | PR-Z3-CW-CS-82-0030 | 113d | 0d |  |  | OK | 1.2.5.20 | PROC | PROC |
| PR-Z3-CW-CS-82-0050 |  | PO - Adtran 850 (for Research Exchange Building) |  | 11.2d | 2016-11-24 | 2016-12-07 | PR-Z3-CW-CS-82-0040 | 113d | 0d |  |  | OK | 1.2.5.20 | PROC | PROC |
| PR-Z3-CW-CS-82-0060 |  | NMR 601 - Adtran 850 (for Research Exchange Building) |  | 4.8d | 2016-12-07 | 2016-12-13 | PR-Z3-CW-CS-82-0050 | 113d | 0d |  |  | OK | 1.2.5.20 | PROC | PROC |
| PR-Z3-CW-CS-82-0070 |  | NMR 602 - Adtran 850 (for Research Exchange Building) |  | 4.8d | 2016-12-13 | 2016-12-18 | PR-Z3-CW-CS-82-0060 | 113d | 0d |  |  | OK | 1.2.5.20 | PROC | PROC |
| PR-Z3-CW-CS-82-0080 |  | Start of Material Delivery - Adtran 850 (for Research Exchange Building) | milestone | 0d | 2017-02-13 | 2017-02-13 | PR-Z3-CW-CS-82-0070 FS+48d | 113d | 0d |  |  | OK | 1.2.5.20 | PROC | PROC |
| PR-Z3-CW-CS-82-0090 |  | Complete Material Delivery - Adtran 850 (for Research Exchange Building) |  | 12d | 2017-02-13 | 2017-02-26 | PR-Z3-CW-CS-82-0080 | 113d | 0d | Adtran 850 [1 ea] | 220,452.75 | OK | 1.2.5.20 | PROC | PROC |
| PR-Z3-CW-CS-82-0100 |  | NMR 603 - Adtran 850 (for Research Exchange Building) |  | 8d | 2017-02-27 | 2017-03-07 | PR-Z3-CW-CS-82-0090 | 273d | 190.8d |  |  | OK | 1.2.5.20 | PROC | PROC |
|  | 14 | **TYPE "L" DOUBLE SIDED MDF 9' X 10 VERTICAL** |  |  | 2016-10-17 | 2017-03-07 |  |  |  |  |  |  |  |  |  |
| PR-Z3-CW-CS-82-0110 |  | RFQ - TYPE "L" DOUBLE SIDED MDF 9' X 10 VERTICAL |  | 5.6d | 2016-10-17 | 2016-10-23 | PR-Z3-CW-CS-82-0010 SS | 125d | 0d |  |  | OK | 1.2.5.20 | PROC | PROC |
| PR-Z3-CW-CS-82-0120 |  | Material Submittal - TYPE "L" DOUBLE SIDED MDF 9' X 10 VER. |  | 8d | 2016-10-24 | 2016-11-01 | PR-Z3-CW-CS-82-0110 | 125d | 0d |  |  | OK | 1.2.5.20 | PROC | PROC |
| PR-Z3-CW-CS-82-0130 |  | Material Approval - TYPE "L" DOUBLE SIDED MDF 9' X 10 VER. |  | 11.2d | 2016-11-02 | 2016-11-15 | PR-Z3-CW-CS-82-0120 | 125d | 0d |  |  | OK | 1.2.5.20 | PROC | PROC |
| PR-Z3-CW-CS-82-0140 |  | Technical Evaluation - TYPE "L" DOUBLE SIDED MDF 9' X 10 VER. |  | 8d | 2016-11-15 | 2016-11-24 | PR-Z3-CW-CS-82-0130 | 125d | 0d |  |  | OK | 1.2.5.20 | PROC | PROC |
| PR-Z3-CW-CS-82-0150 |  | PO - TYPE "L" DOUBLE SIDED MDF 9' X 10 VER. |  | 11.2d | 2016-11-24 | 2016-12-07 | PR-Z3-CW-CS-82-0140 | 125d | 0d |  |  | OK | 1.2.5.20 | PROC | PROC |
| PR-Z3-CW-CS-82-0160 |  | NMR 601 - TYPE "L" DOUBLE SIDED MDF 9' X 10 VER. |  | 4.8d | 2016-12-07 | 2016-12-13 | PR-Z3-CW-CS-82-0150 | 125d | 0d |  |  | OK | 1.2.5.20 | PROC | PROC |
| PR-Z3-CW-CS-82-0170 |  | NMR 602 - TYPE "L" DOUBLE SIDED MDF 9' X 10 VER. |  | 4.8d | 2016-12-13 | 2016-12-18 | PR-Z3-CW-CS-82-0160 | 125d | 0d |  |  | OK | 1.2.5.20 | PROC | PROC |
| PR-Z3-CW-CS-82-0180 |  | Start of Material Delivery - TYPE "L" DOUBLE SIDED MDF 9' X 10 VER. | milestone | 0d | 2017-02-13 | 2017-02-13 | PR-Z3-CW-CS-82-0170 FS+48d | 125d | 0d |  |  | OK | 1.2.5.20 | PROC | PROC |
| PR-Z3-CW-CS-82-0190 |  | Complete Material Delivery - TYPE "L" DOUBLE SIDED MDF 9' X 10 VER. |  | 12d | 2017-02-13 | 2017-02-26 | PR-Z3-CW-CS-82-0180 | 125d | 0d | TYPE "L" DOUBLE SIDED MDF 9' X 10 VERTICAL [1 ea] | 721,481.72 | OK | 1.2.5.20 | PROC | PROC |
| PR-Z3-CW-CS-82-0200 |  | NMR 603 - TYPE "L" DOUBLE SIDED MDF 9' X 10 VER. |  | 8d | 2017-02-27 | 2017-03-07 | PR-Z3-CW-CS-82-0190 | 273d | 190.8d |  |  | OK | 1.2.5.20 | PROC | PROC |
|  | 15 | **Splice Closures & Accessories (for Fire Alarm Interface @ SS# 4 & SS # 5)** |  |  | 2016-10-17 | 2017-03-07 |  |  |  |  |  |  |  |  |  |
| PR-Z3-CW-CS-83-0010 |  | RFQ - Splice Closures & Accessories (for Fire Alarm Interface @ SS# 4 & SS # 5) |  | 5.6d | 2016-10-17 | 2016-10-23 | PROC-GE-GE-GE-0010 FS+55.2d | 47.2d | 0d |  |  | OK | 1.2.5.20 | PROC | PROC |
| PR-Z3-CW-CS-83-0020 |  | Material Submittal - Splice Closures & Accessories (for Fire Alarm Interface @ SS# 4 & SS # 5) |  | 8d | 2016-10-24 | 2016-11-01 | PR-Z3-CW-CS-83-0010 | 47.2d | 0d |  |  | OK | 1.2.5.20 | PROC | PROC |
| PR-Z3-CW-CS-83-0030 |  | Material Approval - Splice Closures & Accessories (for Fire Alarm Interface @ SS# 4 & SS # 5) |  | 11.2d | 2016-11-02 | 2016-11-15 | PR-Z3-CW-CS-83-0020 | 47.2d | 0d |  |  | OK | 1.2.5.20 | PROC | PROC |
| PR-Z3-CW-CS-83-0040 |  | Technical Evaluation - Splice Closures & Accessories (for Fire Alarm Interface @ SS# 4 & SS # 5) |  | 8d | 2016-11-15 | 2016-11-24 | PR-Z3-CW-CS-83-0030 | 47.2d | 0d |  |  | OK | 1.2.5.20 | PROC | PROC |
| PR-Z3-CW-CS-83-0050 |  | PO - Splice Closures & Accessories (for Fire Alarm Interface @ SS# 4 & SS # 5) |  | 11.2d | 2016-11-24 | 2016-12-07 | PR-Z3-CW-CS-83-0040 | 47.2d | 0d |  |  | OK | 1.2.5.20 | PROC | PROC |
| PR-Z3-CW-CS-83-0060 |  | NMR 601 - Splice Closures & Accessories (for Fire Alarm Interface @ SS# 4 & SS # 5) |  | 4.8d | 2016-12-07 | 2016-12-13 | PR-Z3-CW-CS-83-0050 | 47.2d | 0d |  |  | OK | 1.2.5.20 | PROC | PROC |
| PR-Z3-CW-CS-83-0070 |  | NMR 602 - Splice Closures & Accessories (for Fire Alarm Interface @ SS# 4 & SS # 5) |  | 4.8d | 2016-12-13 | 2016-12-18 | PR-Z3-CW-CS-83-0060 | 47.2d | 0d |  |  | OK | 1.2.5.20 | PROC | PROC |
| PR-Z3-CW-CS-83-0080 |  | Start of Material Delivery - Splice Closures & Accessories (for Fire Alarm Interface @ SS# 4 & SS # 5) | milestone | 0d | 2017-02-13 | 2017-02-13 | PR-Z3-CW-CS-83-0070 FS+48d | 47.2d | 0d |  |  | OK | 1.2.5.20 | PROC | PROC |
| PR-Z3-CW-CS-83-0090 |  | Complete Material Delivery - Splice Closures & Accessories (for Fire Alarm Interface @ SS# 4 & SS # 5) |  | 12d | 2017-02-13 | 2017-02-26 | PR-Z3-CW-CS-83-0080 | 47.2d | 0d | Splice Closure [1 ea] | 104,815.26 | OK | 1.2.5.20 | PROC | PROC |
| PR-Z3-CW-CS-83-0100 |  | NMR 603 - Splice Closures & Accessories (for Fire Alarm Interface @ SS# 4 & SS # 5) |  | 8d | 2017-02-27 | 2017-03-07 | PR-Z3-CW-CS-83-0090 | 273d | 190.8d |  |  | OK | 1.2.5.20 | PROC | PROC |

Notes:
- PR-Z3-CW-CS-82-0090: Expenses: (New Expense Item) 220453
- PR-Z3-CW-CS-82-0190: Expenses: (New Expense Item) 721482
- PR-Z3-CW-CS-83-0090: Expenses: (New Expense Item) 104815

| ID | WBS | Activity | Type | Duration | Start | Finish | Predecessors | Total float | Free float | Resources | Cost | Wajid | RPI_P2 - BOQ ITEMS | RPI_P2 - PROCUREMENT | RPI_P2 - PHASE |
| --- | --- | --- | --- | --- | --- | --- | --- | --- | --- | --- | --- | --- | --- | --- | --- |
|  | 16 | **TV Wall Bracket (RP Exchange Building)** |  |  | 2016-10-31 | 2017-04-13 |  |  |  |  |  |  |  |  |  |
| PR-Z3-CW-CS-84-0010 |  | RFQ - TV Wall Bracket & Accessories |  | 5.6d | 2016-10-31 | 2016-11-06 | PROC-GE-GE-GE-0010 FS+67.2d | 241d | 0d |  |  | OK | 1.2.5.20 | PROC | PROC |
| PR-Z3-CW-CS-84-0020 |  | Material Submittal - TV Wall Bracket & Accessories |  | 8d | 2016-11-07 | 2016-11-15 | PR-Z3-CW-CS-84-0010 | 241d | 0d |  |  | OK | 1.2.5.20 | PROC | PROC |
| PR-Z3-CW-CS-84-0030 |  | Material Approval - TV Wall Bracket & Accessories |  | 11.2d | 2016-11-16 | 2016-11-29 | PR-Z3-CW-CS-84-0020 | 241d | 0d |  |  | OK | 1.2.5.20 | PROC | PROC |
| PR-Z3-CW-CS-84-0040 |  | Technical Evaluation - TV Wall Bracket & Accessories |  | 8d | 2016-11-29 | 2016-12-08 | PR-Z3-CW-CS-84-0030 | 241d | 0d |  |  | OK | 1.2.5.20 | PROC | PROC |
| PR-Z3-CW-CS-84-0050 |  | PO - TV Wall Bracket & Accessories |  | 11.2d | 2016-12-08 | 2016-12-21 | PR-Z3-CW-CS-84-0040 | 241d | 0d |  |  | OK | 1.2.5.20 | PROC | PROC |
| PR-Z3-CW-CS-84-0060 |  | NMR 601 - TV Wall Bracket & Accessories |  | 4.8d | 2016-12-21 | 2016-12-27 | PR-Z3-CW-CS-84-0050 | 241d | 0d |  |  | OK | 1.2.5.20 | PROC | PROC |
| PR-Z3-CW-CS-84-0070 |  | NMR 602 - TV Wall Bracket & Accessories |  | 4.8d | 2016-12-27 | 2017-01-01 | PR-Z3-CW-CS-84-0060 | 241d | 0d |  |  | OK | 1.2.5.20 | PROC | PROC |
| PR-Z3-CW-CS-84-0080 |  | Start of Material Delivery - TV Wall Bracket & Accessories | milestone | 0d | 2017-03-22 | 2017-03-22 | PR-Z3-CW-CS-84-0070 FS+68d | 241d | 0d |  |  | OK | 1.2.5.20 | PROC | PROC |
| PR-Z3-CW-CS-84-0090 |  | Complete Material Delivery - TV Wall Bracket & Accessories |  | 12d | 2017-03-22 | 2017-04-04 | PR-Z3-CW-CS-84-0080 | 241d | 0d | TV Wall Brackets & Accessories [6 ea] | 12,024.7 | OK | 1.2.5.20 | PROC | PROC |
| PR-Z3-CW-CS-84-0100 |  | NMR 603 - TV Wall Bracket & Accessories |  | 8d | 2017-04-05 | 2017-04-13 | PR-Z3-CW-CS-84-0090 | 241d | 158.8d |  |  | OK | 1.2.5.20 | PROC | PROC |
|  | 17 | **Code Blue Pedestals** |  |  | 2016-10-17 | 2017-03-14 |  |  |  |  |  |  |  |  |  |
| PR-Z3-CW-CS-85-0010 |  | RFQ - Code Blue Pedestals |  | 5.6d | 2016-10-17 | 2016-10-23 | PROC-GE-GE-GE-0010 FS+55d | 267.6d | 0d |  |  | OK | 1.2.5.20 | PROC | PROC |
| PR-Z3-CW-CS-85-0020 |  | Material Submittal - Code Blue Pedestals |  | 8d | 2016-10-23 | 2016-11-01 | PR-Z3-CW-CS-85-0010 | 267.6d | 0d |  |  | OK | 1.2.5.20 | PROC | PROC |
| PR-Z3-CW-CS-85-0030 |  | Material Approval - Code Blue Pedestals |  | 11.2d | 2016-11-01 | 2016-11-14 | PR-Z3-CW-CS-85-0020 | 267.6d | 0d |  |  | OK | 1.2.5.20 | PROC | PROC |
| PR-Z3-CW-CS-85-0040 |  | Technical Evaluation - Code Blue Pedestals |  | 8d | 2016-11-15 | 2016-11-23 | PR-Z3-CW-CS-85-0030 | 267.6d | 0d |  |  | OK | 1.2.5.20 | PROC | PROC |
| PR-Z3-CW-CS-85-0050 |  | PO - Code Blue Pedestals |  | 11.2d | 2016-11-24 | 2016-12-07 | PR-Z3-CW-CS-85-0040 | 267.6d | 0d |  |  | OK | 1.2.5.20 | PROC | PROC |
| PR-Z3-CW-CS-85-0060 |  | NMR 601 - Code Blue Pedestals |  | 4.8d | 2016-12-07 | 2016-12-12 | PR-Z3-CW-CS-85-0050 | 267.6d | 0d |  |  | OK | 1.2.5.20 | PROC | PROC |
| PR-Z3-CW-CS-85-0070 |  | NMR 602 - Code Blue Pedestals |  | 4.8d | 2016-12-13 | 2016-12-18 | PR-Z3-CW-CS-85-0060 | 267.6d | 0d |  |  | OK | 1.2.5.20 | PROC | PROC |
| PR-Z3-CW-CS-85-0080 |  | Start of Material Delivery - Code Blue Pedestals | milestone | 0d | 2017-02-19 | 2017-02-19 | PR-Z3-CW-CS-85-0070 FS+53.6d | 267.6d | 0d |  |  | OK | 1.2.5.20 | PROC | PROC |
| PR-Z3-CW-CS-85-0090 |  | Complete Material Delivery - Code Blue Pedestals |  | 12d | 2017-02-19 | 2017-03-05 | PR-Z3-CW-CS-85-0080 | 267.6d | 0d | Code Blue Pedestals [17 ea] | 1,533,148.65 | OK | 1.2.5.20 | PROC | PROC |
| PR-Z3-CW-CS-85-0100 |  | NMR 603 - Code Blue Pedestals |  | 8d | 2017-03-05 | 2017-03-14 | PR-Z3-CW-CS-85-0090 | 267.6d | 185.4d |  |  | OK | 1.2.5.20 | PROC | PROC |
|  | 18 | **Code Blue LV Cables** |  |  | 2016-10-17 | 2017-03-14 |  |  |  |  |  |  |  |  |  |
| PR-Z3-CW-CS-86-0010 |  | RFQ - Code Blue LV Cables |  | 5.6d | 2016-10-17 | 2016-10-23 | PROC-GE-GE-GE-0010 FS+47.2d, PR-Z3-CW-CS-85-0010 SS | 267.6d | 0d |  |  | OK | 1.2.5.20 | PROC | PROC |
| PR-Z3-CW-CS-86-0020 |  | Material Submittal - Code Blue LV Cables |  | 8d | 2016-10-23 | 2016-11-01 | PR-Z3-CW-CS-86-0010 | 267.6d | 0d |  |  | OK | 1.2.5.20 | PROC | PROC |
| PR-Z3-CW-CS-86-0030 |  | Material Approval - Code Blue LV Cables |  | 11.2d | 2016-11-01 | 2016-11-14 | PR-Z3-CW-CS-86-0020 | 267.6d | 0d |  |  | OK | 1.2.5.20 | PROC | PROC |
| PR-Z3-CW-CS-86-0040 |  | Technical Evaluation - Code Blue LV Cables |  | 8d | 2016-11-15 | 2016-11-23 | PR-Z3-CW-CS-86-0030 | 267.6d | 0d |  |  | OK | 1.2.5.20 | PROC | PROC |
| PR-Z3-CW-CS-86-0050 |  | PO - Code Blue LV Cables |  | 11.2d | 2016-11-24 | 2016-12-07 | PR-Z3-CW-CS-86-0040 | 267.6d | 0d |  |  | OK | 1.2.5.20 | PROC | PROC |
| PR-Z3-CW-CS-86-0060 |  | NMR 601 - Code Blue LV Cables |  | 4.8d | 2016-12-07 | 2016-12-12 | PR-Z3-CW-CS-86-0050 | 267.6d | 0d |  |  | OK | 1.2.5.20 | PROC | PROC |
| PR-Z3-CW-CS-86-0070 |  | NMR 602 - Code Blue LV Cables |  | 4.8d | 2016-12-13 | 2016-12-18 | PR-Z3-CW-CS-86-0060 | 267.6d | 0d |  |  | OK | 1.2.5.20 | PROC | PROC |
| PR-Z3-CW-CS-86-0080 |  | Start of Material Delivery - Code Blue LV Cables | milestone | 0d | 2017-02-19 | 2017-02-19 | PR-Z3-CW-CS-86-0070 FS+53.6d | 267.6d | 0d |  |  | OK | 1.2.5.20 | PROC | PROC |
| PR-Z3-CW-CS-86-0090 |  | Complete Material Delivery - Code Blue LV Cables |  | 12d | 2017-02-19 | 2017-03-05 | PR-Z3-CW-CS-86-0080 | 267.6d | 0d | Code Blue LV Cables [5977 Lm] | 162,669.4 | OK | 1.2.5.20 | PROC | PROC |
| PR-Z3-CW-CS-86-0100 |  | NMR 603 - Code Blue LV Cables |  | 8d | 2017-03-05 | 2017-03-14 | PR-Z3-CW-CS-86-0090 | 267.6d | 185.4d |  |  | OK | 1.2.5.20 | PROC | PROC |

Notes:
- PR-Z3-CW-CS-84-0090: Expenses: (New Expense Item) 12024.7
- PR-Z3-CW-CS-85-0090: Expenses: (New Expense Item) 1533149
- PR-Z3-CW-CS-86-0090: Expenses: (New Expense Item) 162669

| ID | WBS | Activity | Type | Duration | Start | Finish | Predecessors | Total float | Free float | Resources | Cost | Wajid | RPI_P2 - BOQ ITEMS | RPI_P2 - PROCUREMENT | RPI_P2 - PHASE |
| --- | --- | --- | --- | --- | --- | --- | --- | --- | --- | --- | --- | --- | --- | --- | --- |
|  | 19 | **Code Blue Pedestals - Concrete Foundations Incl. Accessories (CCTV Camera, Code Blue Pedestals)** |  |  | 2016-10-11 | 2017-04-16 |  |  |  |  |  |  |  |  |  |
| PR-Z3-CW-CS-87-0010 |  | RFQ - Concrete Foundations Incl. Accessories (CCTV Camera, Code Blue Pedestals) |  | 5.6d | 2016-10-11 | 2016-10-17 | PROC-GE-GE-GE-0010 FS+50d | 239.6d | 0d |  |  | OK | 1.2.5.20 | PROC | PROC |
| PR-Z3-CW-CS-87-0020 |  | Material Submittal - Concrete Foundations Incl. Accessories (CCTV Camera, Code Blue Pedestals) |  | 8d | 2016-10-17 | 2016-10-26 | PR-Z3-CW-CS-87-0010 | 239.6d | 0d |  |  | OK | 1.2.5.20 | PROC | PROC |
| PR-Z3-CW-CS-87-0030 |  | Material Approval - Concrete Foundations Incl. Accessories (CCTV Camera, Code Blue Pedestals) |  | 11.2d | 2016-10-26 | 2016-11-08 | PR-Z3-CW-CS-87-0020 | 239.6d | 0d |  |  | OK | 1.2.5.20 | PROC | PROC |
| PR-Z3-CW-CS-87-0040 |  | Technical Evaluation - Concrete Foundations Incl. Accessories (CCTV Camera, Code Blue Pedestals) |  | 8d | 2016-11-09 | 2016-11-17 | PR-Z3-CW-CS-87-0030 | 239.6d | 0d |  |  | OK | 1.2.5.20 | PROC | PROC |
| PR-Z3-CW-CS-87-0050 |  | PO - Concrete Foundations Incl. Accessories (CCTV Camera, Code Blue Pedestals) |  | 11.2d | 2016-11-19 | 2016-12-01 | PR-Z3-CW-CS-87-0040 | 239.6d | 0d |  |  | OK | 1.2.5.20 | PROC | PROC |
| PR-Z3-CW-CS-87-0060 |  | NMR 601 - Concrete Foundations Incl. Accessories (CCTV Camera, Code Blue Pedestals) |  | 4.8d | 2016-12-01 | 2016-12-06 | PR-Z3-CW-CS-87-0050 | 239.6d | 0d |  |  | OK | 1.2.5.20 | PROC | PROC |
| PR-Z3-CW-CS-87-0070 |  | NMR 602 - Concrete Foundations Incl. Accessories (CCTV Camera, Code Blue Pedestals) |  | 4.8d | 2016-12-07 | 2016-12-12 | PR-Z3-CW-CS-87-0060 | 239.6d | 0d |  |  | OK | 1.2.5.20 | PROC | PROC |
| PR-Z3-CW-CS-87-0080 |  | Start of Material Delivery - Concrete Foundations Incl. Accessories (CCTV Camera, Code Blue Pedestals) | milestone | 0d | 2017-02-13 | 2017-02-13 | PR-Z3-CW-CS-87-0070 FS+53.6d | 239.6d | 0d |  |  | OK | 1.2.5.20 | PROC | PROC |
| PR-Z3-CW-CS-87-0090 |  | Complete Material Delivery - Concrete Foundations Incl. Accessories (CCTV Camera, Code Blue Pedestals) |  | 45d | 2017-02-13 | 2017-04-06 | PR-Z3-CW-CS-87-0080 | 239.6d | 0d | Concrete Foundation [72 ea] | 101,157.75 | OK | 1.2.5.20 | PROC | PROC |
| PR-Z3-CW-CS-87-0100 |  | NMR 603 - Concrete Foundations Incl. Accessories (CCTV Camera, Code Blue Pedestals) |  | 8d | 2017-04-06 | 2017-04-16 | PR-Z3-CW-CS-87-0090 | 239.6d | 157.4d |  |  | OK | 1.2.5.20 | PROC | PROC |
|  | 3 | **Communication manhole and Conduit System** |  |  | 2016-08-28 | 2017-02-04 |  |  |  |  |  |  |  |  |  |
|  | 1 | **Ground Cables & Accessories** |  |  | 2016-09-07 | 2017-01-17 |  |  |  |  |  |  |  |  |  |
| PR-Z3-CW-CS-88-0010 |  | RFQ - Ground Cables & Accessories |  | 5.6d | 2016-09-07 | 2016-09-18 | PR-Z3-EW-EW-38-0010 SS, PROC-GE-GE-GE-0010 FS+7.2d | 115.2d | 0d |  |  | OK | 1.2.5.30 | PROC | PROC |
| PR-Z3-CW-CS-88-0020 |  | Material Submittal - Ground Cables & Accessories |  | 8d | 2016-09-18 | 2016-09-27 | PR-Z3-CW-CS-88-0010 | 115.2d | 0d |  |  | OK | 1.2.5.30 | PROC | PROC |
| PR-Z3-CW-CS-88-0030 |  | Material Approval - Ground Cables & Accessories |  | 11.2d | 2016-09-27 | 2016-10-10 | PR-Z3-CW-CS-88-0020 | 115.2d | 0d |  |  | OK | 1.2.5.30 | PROC | PROC |
| PR-Z3-CW-CS-88-0040 |  | Technical Evaluation - Ground Cables & Accessories |  | 8d | 2016-10-11 | 2016-10-19 | PR-Z3-CW-CS-88-0030 | 115.2d | 0d |  |  | OK | 1.2.5.30 | PROC | PROC |
| PR-Z3-CW-CS-88-0050 |  | PO - Ground Cables & Accessories |  | 11.2d | 2016-10-20 | 2016-11-02 | PR-Z3-CW-CS-88-0040 | 115.2d | 0d |  |  | OK | 1.2.5.30 | PROC | PROC |
| PR-Z3-CW-CS-88-0060 |  | NMR 601 - Ground Cables & Accessories |  | 4.8d | 2016-11-02 | 2016-11-07 | PR-Z3-CW-CS-88-0050 | 115.2d | 0d |  |  | OK | 1.2.5.30 | PROC | PROC |
| PR-Z3-CW-CS-88-0070 |  | NMR 602 - Ground Cables & Accessories |  | 4.8d | 2016-11-08 | 2016-11-13 | PR-Z3-CW-CS-88-0060 | 115.2d | 0d |  |  | OK | 1.2.5.30 | PROC | PROC |
| PR-Z3-CW-CS-88-0080 |  | Start of Material Delivery - Ground Cables & Accessories | milestone | 0d | 2016-12-25 | 2016-12-25 | PR-Z3-CW-CS-88-0070 FS+36d | 115.2d | 0d |  |  | OK | 1.2.5.30 | PROC | PROC |
| PR-Z3-CW-CS-88-0090 |  | Complete Material Delivery - Ground Cables & Accessories |  | 12d | 2016-12-25 | 2017-01-08 | PR-Z3-CW-CS-88-0080 | 115.2d | 0d | Ground Cable and Accessories [314 Lm] | 10,617.76 | OK | 1.2.5.30 | PROC | PROC |
| PR-Z3-CW-CS-88-0100 |  | NMR 603 - Ground Cables & Accessories |  | 8d | 2017-01-08 | 2017-01-17 | PR-Z3-CW-CS-88-0090 | 315.2d | 233d |  |  | OK | 1.2.5.30 | PROC | PROC |
|  | 2 | **Manhole Frame & Covers** |  |  | 2016-09-15 | 2017-02-04 |  |  |  |  |  |  |  |  |  |
| PR-Z3-CW-CS-89-0010 |  | RFQ - Manhole Frame & Covers |  | 5.6d | 2016-09-15 | 2016-09-21 | PROC-GE-GE-GE-0010 FS+28d | 94.2d | 0d |  |  | OK | 1.2.5.30 | PROC | PROC |
| PR-Z3-CW-CS-89-0020 |  | Material Submittal - Manhole Frame & Covers |  | 8d | 2016-09-21 | 2016-10-01 | PR-Z3-CW-CS-89-0010 | 94.2d | 0d |  |  | OK | 1.2.5.30 | PROC | PROC |
| PR-Z3-CW-CS-89-0030 |  | Material Approval - Manhole Frame & Covers |  | 11.2d | 2016-10-01 | 2016-10-13 | PR-Z3-CW-CS-89-0020 | 94.2d | 0d |  |  | OK | 1.2.5.30 | PROC | PROC |
| PR-Z3-CW-CS-89-0040 |  | Technical Evaluation - Manhole Frame & Covers |  | 8d | 2016-10-15 | 2016-10-23 | PR-Z3-CW-CS-89-0030 | 94.2d | 0d |  |  | OK | 1.2.5.30 | PROC | PROC |
| PR-Z3-CW-CS-89-0050 |  | PO - Manhole Frame & Covers |  | 11.2d | 2016-10-24 | 2016-11-06 | PR-Z3-CW-CS-89-0040 | 94.2d | 0d |  |  | OK | 1.2.5.30 | PROC | PROC |
| PR-Z3-CW-CS-89-0060 |  | NMR 601 - Manhole Frame & Covers |  | 4.8d | 2016-11-06 | 2016-11-10 | PR-Z3-CW-CS-89-0050 | 94.2d | 0d |  |  | OK | 1.2.5.30 | PROC | PROC |
| PR-Z3-CW-CS-89-0070 |  | NMR 602 - Manhole Frame & Covers |  | 4.8d | 2016-11-12 | 2016-11-16 | PR-Z3-CW-CS-89-0060 | 94.2d | 0d |  |  | OK | 1.2.5.30 | PROC | PROC |
| PR-Z3-CW-CS-89-0080 |  | Start of Material Delivery - Manhole Frame & Covers | milestone | 0d | 2017-01-11 | 2017-01-11 | PR-Z3-CW-CS-89-0070 FS+48d | 94.2d | 0d |  |  | OK | 1.2.5.30 | PROC | PROC |
| PR-Z3-CW-CS-89-0090 |  | Complete Material Delivery - Manhole Frame & Covers |  | 12d | 2017-01-11 | 2017-01-25 | PR-Z3-CW-CS-89-0080 | 94.2d | 0d | Manhole Frame & Covers [16 ea] | 8,863.97 | OK | 1.2.5.30 | PROC | PROC |
| PR-Z3-CW-CS-89-0100 |  | NMR 603 - Manhole Frame & Covers |  | 8d | 2017-01-25 | 2017-02-04 | PR-Z3-CW-CS-89-0090 | 300.2d | 218d |  |  | OK | 1.2.5.30 | PROC | PROC |

Notes:
- PR-Z3-CW-CS-87-0090: Expenses: (New Expense Item) 101158
- PR-Z3-CW-CS-88-0090: Expenses: (New Expense Item) 10617.8
- PR-Z3-CW-CS-89-0090: Expenses: (New Expense Item) 8863.97

| ID | WBS | Activity | Type | Duration | Start | Finish | Predecessors | Total float | Free float | Resources | Cost | Wajid | RPI_P2 - BOQ ITEMS | RPI_P2 - PROCUREMENT | RPI_P2 - PHASE |
| --- | --- | --- | --- | --- | --- | --- | --- | --- | --- | --- | --- | --- | --- | --- | --- |
|  | 3 | **Warning Tape (for Comminication Duct Banks)** |  |  | 2016-08-28 | 2017-01-26 |  |  |  |  |  |  |  |  |  |
| PR-Z3-CW-CS-90-0010 |  | RFQ - Warning Tape (for Comminication Duct Banks) |  | 5.6d | 2016-08-28 | 2016-09-03 | PROC-GE-GE-GE-0010 FS+15.2d, PR-Z3-EW-EW-40-0010 SS | 114.4d | 0d |  |  | OK | 1.2.5.30 | PROC | PROC |
| PR-Z3-CW-CS-90-0020 |  | Material Submittal - Warning Tape (for Comminication Duct Banks) |  | 8d | 2016-09-03 | 2016-09-17 | PR-Z3-CW-CS-90-0010 | 114.4d | 0d |  |  | OK | 1.2.5.30 | PROC | PROC |
| PR-Z3-CW-CS-90-0030 |  | Material Approval - Warning Tape (for Comminication Duct Banks) |  | 11.2d | 2016-09-17 | 2016-09-29 | PR-Z3-CW-CS-90-0020 | 114.4d | 0d |  |  | OK | 1.2.5.30 | PROC | PROC |
| PR-Z3-CW-CS-90-0040 |  | Technical Evaluation - Warning Tape (for Comminication Duct Banks) |  | 8d | 2016-10-01 | 2016-10-09 | PR-Z3-CW-CS-90-0030 | 114.4d | 0d |  |  | OK | 1.2.5.30 | PROC | PROC |
| PR-Z3-CW-CS-90-0050 |  | PO - Warning Tape (for Comminication Duct Banks) |  | 11.2d | 2016-10-10 | 2016-10-23 | PR-Z3-CW-CS-90-0040 | 114.4d | 0d |  |  | OK | 1.2.5.30 | PROC | PROC |
| PR-Z3-CW-CS-90-0060 |  | NMR 601 - Warning Tape (for Comminication Duct Banks) |  | 4.8d | 2016-10-23 | 2016-10-27 | PR-Z3-CW-CS-90-0050 | 114.4d | 0d |  |  | OK | 1.2.5.30 | PROC | PROC |
| PR-Z3-CW-CS-90-0070 |  | NMR 602 - Warning Tape (for Comminication Duct Banks) |  | 4.8d | 2016-10-29 | 2016-11-02 | PR-Z3-CW-CS-90-0060 | 114.4d | 0d |  |  | OK | 1.2.5.30 | PROC | PROC |
| PR-Z3-CW-CS-90-0080 |  | Start of Material Delivery - Warning Tape (for Comminication Duct Banks) | milestone | 0d | 2016-11-08 | 2016-11-08 | PR-Z3-CW-CS-90-0070 FS+4.8d | 114.4d | 0d |  |  | OK | 1.2.5.30 | PROC | PROC |
| PR-Z3-CW-CS-90-0090 |  | Complete Material Delivery - Warning Tape (for Comminication Duct Banks) |  | 60d | 2016-11-08 | 2017-01-17 | PR-Z3-CW-CS-90-0080 | 114.4d | 0d | Warning Tapes [3847 Lm] | 15,223.07 | OK | 1.2.5.30 | PROC | PROC |
| PR-Z3-CW-CS-90-0100 |  | NMR 603 - Warning Tape (for Comminication Duct Banks) |  | 8d | 2017-01-17 | 2017-01-26 | PR-Z3-CW-CS-90-0090 | 307.4d | 225.2d |  |  | OK | 1.2.5.30 | PROC | PROC |
|  | 4 | **Miscellaneous Communication Items** |  |  | 2016-09-01 | 2017-03-12 |  |  |  |  |  |  |  |  |  |
|  | 1 | **PVC Sub-ducts (for Communication)** |  |  | 2016-09-01 | 2017-01-25 |  |  |  |  |  |  |  |  |  |
| PR-Z3-CW-CS-91-0010 |  | RFQ - PVC Sub-ducts (for Communication) |  | 5.6d | 2016-09-01 | 2016-09-07 | PR-MT-Z1-LC-13-0010 SS, PROC-GE-GE-GE-0010 FS+20d | 0.4d | 0d |  |  | OK | 1.2.5.40 | PROC | PROC |
| PR-Z3-CW-CS-91-0020 |  | Material Submittal - PVC Sub-ducts (for Communication) |  | 8d | 2016-09-07 | 2016-09-21 | PR-Z3-CW-CS-91-0010 | 0.4d | 0d |  |  | OK | 1.2.5.40 | PROC | PROC |
| PR-Z3-CW-CS-91-0030 |  | Material Approval - PVC Sub-ducts (for Communication) |  | 11.2d | 2016-09-21 | 2016-10-04 | PR-Z3-CW-CS-91-0020 | 0.4d | 0d |  |  | OK | 1.2.5.40 | PROC | PROC |
| PR-Z3-CW-CS-91-0040 |  | Technical Evaluation - PVC Sub-ducts (for Communication) |  | 8d | 2016-10-05 | 2016-10-13 | PR-Z3-CW-CS-91-0030 | 0.4d | 0d |  |  | OK | 1.2.5.40 | PROC | PROC |
| PR-Z3-CW-CS-91-0050 |  | PO - PVC Sub-ducts (for Communication) |  | 11.2d | 2016-10-15 | 2016-10-27 | PR-Z3-CW-CS-91-0040 | 0.4d | 0d |  |  | OK | 1.2.5.40 | PROC | PROC |
| PR-Z3-CW-CS-91-0060 |  | NMR 601 - PVC Sub-ducts (for Communication) |  | 4.8d | 2016-10-27 | 2016-11-01 | PR-Z3-CW-CS-91-0050 | 0.4d | 0d |  |  | OK | 1.2.5.40 | PROC | PROC |
| PR-Z3-CW-CS-91-0070 |  | NMR 602 - PVC Sub-ducts (for Communication) |  | 4.8d | 2016-11-02 | 2016-11-07 | PR-Z3-CW-CS-91-0060 | 0.4d | 0d |  |  | OK | 1.2.5.40 | PROC | PROC |
| PR-Z3-CW-CS-91-0080 |  | Start of Material Delivery - PVC Sub-ducts (for Communication) | milestone | 0d | 2016-12-12 | 2016-12-12 | PR-Z3-CW-CS-91-0070 FS+29.6d | 0.4d | 0d |  |  | OK | 1.2.5.40 | PROC | PROC |
| PR-Z3-CW-CS-91-0090 |  | Complete Material Delivery - PVC Sub-ducts (for Communication) |  | 30d | 2016-12-12 | 2017-01-16 | PR-Z3-CW-CS-91-0080 | 0.4d | 0d | PVC Sub-ducts [1198 Lm] | 10,042.15 | OK | 1.2.5.40 | PROC | PROC |
| PR-Z3-CW-CS-91-0100 |  | NMR 603 - PVC Sub-ducts (for Communication) |  | 8d | 2017-01-16 | 2017-01-25 | PR-Z3-CW-CS-91-0090 | 308.6d | 226.4d |  |  | OK | 1.2.5.40 | PROC | PROC |
|  | 2 | **Sub-ducts Plugging ( for Communication)** |  |  | 2016-09-01 | 2017-01-04 |  |  |  |  |  |  |  |  |  |
| PR-Z3-CW-CS-92-0010 |  | RFQ - Sub-ducts Plugging ( for Communication) |  | 5.6d | 2016-09-01 | 2016-09-07 | PROC-GE-GE-GE-0010 FS+20d | 326.6d | 0d |  |  | OK | 1.2.5.40 | PROC | PROC |
| PR-Z3-CW-CS-92-0020 |  | Material Submittal - Sub-ducts Plugging ( for Communication) |  | 8d | 2016-09-07 | 2016-09-21 | PR-Z3-CW-CS-92-0010 | 326.6d | 0d |  |  | OK | 1.2.5.40 | PROC | PROC |
| PR-Z3-CW-CS-92-0030 |  | Material Approval - Sub-ducts Plugging ( for Communication) |  | 11.2d | 2016-09-21 | 2016-10-04 | PR-Z3-CW-CS-92-0020 | 326.6d | 0d |  |  | OK | 1.2.5.40 | PROC | PROC |
| PR-Z3-CW-CS-92-0040 |  | Technical Evaluation - Sub-ducts Plugging ( for Communication) |  | 8d | 2016-10-05 | 2016-10-13 | PR-Z3-CW-CS-92-0030 | 326.6d | 0d |  |  | OK | 1.2.5.40 | PROC | PROC |
| PR-Z3-CW-CS-92-0050 |  | PO - Sub-ducts Plugging ( for Communication) |  | 11.2d | 2016-10-15 | 2016-10-27 | PR-Z3-CW-CS-92-0040 | 326.6d | 0d |  |  | OK | 1.2.5.40 | PROC | PROC |
| PR-Z3-CW-CS-92-0060 |  | NMR 601 - Sub-ducts Plugging ( for Communication) |  | 4.8d | 2016-10-27 | 2016-11-01 | PR-Z3-CW-CS-92-0050 | 326.6d | 0d |  |  | OK | 1.2.5.40 | PROC | PROC |
| PR-Z3-CW-CS-92-0070 |  | NMR 602 - Sub-ducts Plugging ( for Communication) |  | 4.8d | 2016-11-02 | 2016-11-07 | PR-Z3-CW-CS-92-0060 | 326.6d | 0d |  |  | OK | 1.2.5.40 | PROC | PROC |
| PR-Z3-CW-CS-92-0080 |  | Start of Material Delivery - Sub-ducts Plugging ( for Communication) | milestone | 0d | 2016-12-12 | 2016-12-12 | PR-Z3-CW-CS-92-0070 FS+29.6d | 326.6d | 0d |  |  | OK | 1.2.5.40 | PROC | PROC |
| PR-Z3-CW-CS-92-0090 |  | Complete Material Delivery - Sub-ducts Plugging ( for Communication) |  | 12d | 2016-12-12 | 2016-12-26 | PR-Z3-CW-CS-92-0080 | 326.6d | 0d | Sub-ducts Plugging [5 ea] | 1,746.34 | OK | 1.2.5.40 | PROC | PROC |
| PR-Z3-CW-CS-92-0100 |  | NMR 603 - Sub-ducts Plugging ( for Communication) |  | 8d | 2016-12-26 | 2017-01-04 | PR-Z3-CW-CS-92-0090 | 326.6d | 244.4d |  |  | OK | 1.2.5.40 | PROC | PROC |

Notes:
- PR-Z3-CW-CS-90-0090: Expenses: (New Expense Item) 15223.1
- PR-Z3-CW-CS-91-0090: Expenses: (New Expense Item) 10042.1
- PR-Z3-CW-CS-92-0090: Expenses: (New Expense Item) 1746.34

| ID | WBS | Activity | Type | Duration | Start | Finish | Predecessors | Total float | Free float | Wajid | RPI_P2 - BOQ ITEMS | RPI_P2 - PROCUREMENT | RPI_P2 - PHASE |
| --- | --- | --- | --- | --- | --- | --- | --- | --- | --- | --- | --- | --- | --- |
|  | 3 | **SACS System** |  |  | 2016-10-26 | 2017-03-07 |  |  |  |  |  |  |  |
| PR-Z3-GE-GE-245-0010 |  | RFQ - SACS System |  | 5.6d | 2016-10-26 | 2016-11-01 | PROC-GE-GE-GE-0010 FS+63.2d | 273d | 0d | OK | 1.2.5.40 | PROC | PROC |
| PR-Z3-GE-GE-245-0020 |  | Material Submittal - SACS System |  | 8d | 2016-11-02 | 2016-11-10 | PR-Z3-GE-GE-245-0010 | 273d | 0d | OK | 1.2.5.40 | PROC | PROC |
| PR-Z3-GE-GE-245-0030 |  | Material Approval - SACS System |  | 11.2d | 2016-11-12 | 2016-11-24 | PR-Z3-GE-GE-245-0020 | 273d | 0d | OK | 1.2.5.40 | PROC | PROC |
| PR-Z3-GE-GE-245-0040 |  | Technical Evaluation - SACS System |  | 8d | 2016-11-24 | 2016-12-04 | PR-Z3-GE-GE-245-0030 | 273d | 0d | OK | 1.2.5.40 | PROC | PROC |
| PR-Z3-GE-GE-245-0050 |  | PO - SACS System |  | 11.2d | 2016-12-04 | 2016-12-17 | PR-Z3-GE-GE-245-0040 | 273d | 0d | OK | 1.2.5.40 | PROC | PROC |
| PR-Z3-GE-GE-245-0060 |  | NMR 601 - SACS System |  | 4.8d | 2016-12-17 | 2016-12-22 | PR-Z3-GE-GE-245-0050 | 273d | 0d | OK | 1.2.5.40 | PROC | PROC |
| PR-Z3-GE-GE-245-0070 |  | NMR 602 - SACS System |  | 4.8d | 2016-12-22 | 2016-12-27 | PR-Z3-GE-GE-245-0060 | 273d | 0d | OK | 1.2.5.40 | PROC | PROC |
| PR-Z3-GE-GE-245-0080 |  | Start of Material Delivery - SACS System | milestone | 0d | 2017-02-13 | 2017-02-13 | PR-Z3-GE-GE-245-0070 FS+40d | 273d | 0d | OK | 1.2.5.40 | PROC | PROC |
| PR-Z3-GE-GE-245-0090 |  | Complete Material Delivery - SACS System |  | 12d | 2017-02-13 | 2017-02-26 | PR-Z3-GE-GE-245-0080 | 273d | 0d | OK | 1.2.5.40 | PROC | PROC |
| PR-Z3-GE-GE-245-0100 |  | NMR 603 - SACS System |  | 8d | 2017-02-27 | 2017-03-07 | PR-Z3-GE-GE-245-0090 | 273d | 190.8d | OK | 1.2.5.40 | PROC | PROC |
|  | 4 | **CCTV System** |  |  | 2016-10-22 | 2017-03-12 |  |  |  |  |  |  |  |
| PR-Z3-GE-GE-246-0010 |  | RFQ - CCTV System |  | 5.6d | 2016-10-22 | 2016-10-27 | PROC-GE-GE-GE-0010 FS+59.2d | 269.8d | 0d | OK | 1.2.5.40 | PROC | PROC |
| PR-Z3-GE-GE-246-0020 |  | Material Submittal - CCTV System |  | 8d | 2016-10-29 | 2016-11-06 | PR-Z3-GE-GE-246-0010 | 269.8d | 0d | OK | 1.2.5.40 | PROC | PROC |
| PR-Z3-GE-GE-246-0030 |  | Material Approval - CCTV System |  | 11.2d | 2016-11-07 | 2016-11-20 | PR-Z3-GE-GE-246-0020 | 269.8d | 0d | OK | 1.2.5.40 | PROC | PROC |
| PR-Z3-GE-GE-246-0040 |  | Technical Evaluation - CCTV System |  | 8d | 2016-11-20 | 2016-11-29 | PR-Z3-GE-GE-246-0030 | 269.8d | 0d | OK | 1.2.5.40 | PROC | PROC |
| PR-Z3-GE-GE-246-0050 |  | PO - CCTV System |  | 11.2d | 2016-11-29 | 2016-12-12 | PR-Z3-GE-GE-246-0040 | 269.8d | 0d | OK | 1.2.5.40 | PROC | PROC |
| PR-Z3-GE-GE-246-0060 |  | NMR 601 - CCTV System |  | 4.8d | 2016-12-12 | 2016-12-18 | PR-Z3-GE-GE-246-0050 | 269.8d | 0d | OK | 1.2.5.40 | PROC | PROC |
| PR-Z3-GE-GE-246-0070 |  | NMR 602 - CCTV System |  | 4.8d | 2016-12-18 | 2016-12-22 | PR-Z3-GE-GE-246-0060 | 269.8d | 0d | OK | 1.2.5.40 | PROC | PROC |
| PR-Z3-GE-GE-246-0080 |  | Start of Material Delivery - CCTV System | milestone | 0d | 2017-02-16 | 2017-02-16 | PR-Z3-GE-GE-246-0070 FS+47.2d | 269.8d | 0d | OK | 1.2.5.40 | PROC | PROC |
| PR-Z3-GE-GE-246-0090 |  | Complete Material Delivery - CCTV System |  | 12d | 2017-02-16 | 2017-03-02 | PR-Z3-GE-GE-246-0080 | 269.8d | 0d | OK | 1.2.5.40 | PROC | PROC |
| PR-Z3-GE-GE-246-0100 |  | NMR 603 - CCTV System |  | 8d | 2017-03-02 | 2017-03-12 | PR-Z3-GE-GE-246-0090 | 269.8d | 187.6d | OK | 1.2.5.40 | PROC | PROC |
|  | 5 | **IP Phone System** |  |  | 2016-10-22 | 2017-01-15 |  |  |  |  |  |  |  |
| PR-Z3-GE-GE-247-0010 |  | RFQ - IP Phone System |  | 5.6d | 2016-10-22 | 2016-10-27 | PROC-GE-GE-GE-0010 FS+59.2d | 33.4d | 0d | OK | 1.2.5.40 | PROC | PROC |
| PR-Z3-GE-GE-247-0020 |  | Material Submittal - IP Phone System |  | 8d | 2016-10-29 | 2016-11-06 | PR-Z3-GE-GE-247-0010 | 33.4d | 0d | OK | 1.2.5.40 | PROC | PROC |
| PR-Z3-GE-GE-247-0030 |  | Material Approval - IP Phone System |  | 11.2d | 2016-11-07 | 2016-11-20 | PR-Z3-GE-GE-247-0020 | 33.4d | 0d | OK | 1.2.5.40 | PROC | PROC |
| PR-Z3-GE-GE-247-0040 |  | Technical Evaluation - IP Phone System |  | 8d | 2016-11-20 | 2016-11-29 | PR-Z3-GE-GE-247-0030 | 33.4d | 0d | OK | 1.2.5.40 | PROC | PROC |
| PR-Z3-GE-GE-247-0050 |  | PO - IP Phone System |  | 11.2d | 2016-11-29 | 2016-12-12 | PR-Z3-GE-GE-247-0040 | 33.4d | 0d | OK | 1.2.5.40 | PROC | PROC |
| PR-Z3-GE-GE-247-0060 |  | NMR 601 - IP Phone System |  | 4.8d | 2016-12-12 | 2016-12-18 | PR-Z3-GE-GE-247-0050 | 33.4d | 0d | OK | 1.2.5.40 | PROC | PROC |
| PR-Z3-GE-GE-247-0070 |  | NMR 602 - IP Phone System |  | 4.8d | 2016-12-18 | 2016-12-22 | PR-Z3-GE-GE-247-0060 | 33.4d | 0d | OK | 1.2.5.40 | PROC | PROC |
| PR-Z3-GE-GE-247-0080 |  | Start of Material Delivery - IP Phone System | milestone | 0d | 2016-12-24 | 2016-12-24 | PR-Z3-GE-GE-247-0070 | 33.4d | 0d | OK | 1.2.5.40 | PROC | PROC |
| PR-Z3-GE-GE-247-0090 |  | Complete Material Delivery - IP Phone System |  | 12d | 2016-12-24 | 2017-01-05 | PR-Z3-GE-GE-247-0080 | 33.4d | 0d | OK | 1.2.5.40 | PROC | PROC |
| PR-Z3-GE-GE-247-0100 |  | NMR 603 - IP Phone System |  | 8d | 2017-01-07 | 2017-01-15 | PR-Z3-GE-GE-247-0090 | 317d | 234.8d | OK | 1.2.5.40 | PROC | PROC |

| ID | WBS | Activity | Type | Duration | Start | Finish | Predecessors | Total float | Free float | Resources | Cost | Wajid | RPI_P2 - BOQ ITEMS | RPI_P2 - PROCUREMENT | RPI_P2 - PHASE |
| --- | --- | --- | --- | --- | --- | --- | --- | --- | --- | --- | --- | --- | --- | --- | --- |
|  | 4 | **LANDSCAPING WORKS - (MATERIALS)** |  |  | 2016-08-23 | 2017-10-26 |  |  |  |  |  |  |  |  |  |
|  | 1 | **All Palm Trees, Plants, Shurbs, Turfing & Soft Landscaping Material** |  |  | 2016-11-09 | 2017-10-26 |  |  |  |  |  |  |  |  |  |
|  | 1 | **Palm Trees** |  |  | 2016-11-15 | 2017-10-02 |  |  |  |  |  |  |  |  |  |
| PR-Z3-LW-LS-93-0010 |  | RFQ - Palm Trees |  | 5.6d | 2016-11-15 | 2016-11-21 | PROC-GE-GE-GE-0010 FS+80d | 57.2d | 0d |  |  | OK | 1.2.6.10 | PROC | PROC |
| PR-Z3-LW-LS-93-0020 |  | Material Submittal - Palm Trees |  | 8d | 2016-11-21 | 2016-11-30 | PR-Z3-LW-LS-93-0010 | 57.2d | 0d |  |  | OK | 1.2.6.10 | PROC | PROC |
| PR-Z3-LW-LS-93-0030 |  | Material Approval - Palm Trees |  | 11.2d | 2016-11-30 | 2016-12-13 | PR-Z3-LW-LS-93-0020 | 57.2d | 0d |  |  | OK | 1.2.6.10 | PROC | PROC |
| PR-Z3-LW-LS-93-0040 |  | Technical Evaluation - Palm Trees |  | 8d | 2016-12-14 | 2016-12-22 | PR-Z3-LW-LS-93-0030 | 57.2d | 0d |  |  | OK | 1.2.6.10 | PROC | PROC |
| PR-Z3-LW-LS-93-0050 |  | PO - Palm Trees |  | 11.2d | 2016-12-24 | 2017-01-05 | PR-Z3-LW-LS-93-0040 | 57.2d | 0d |  |  | OK | 1.2.6.10 | PROC | PROC |
| PR-Z3-LW-LS-93-0060 |  | NMR 601 - Palm Trees |  | 4.8d | 2017-01-05 | 2017-01-10 | PR-Z3-LW-LS-93-0050 | 57.2d | 0d |  |  | OK | 1.2.6.10 | PROC | PROC |
| PR-Z3-LW-LS-93-0070 |  | NMR 602 - Palm Trees |  | 4.8d | 2017-01-11 | 2017-01-16 | PR-Z3-LW-LS-93-0060 | 57.2d | 0d |  |  | OK | 1.2.6.10 | PROC | PROC |
| PR-Z3-LW-LS-93-0080 |  | Start of Material Delivery - Palm Trees | milestone | 0d | 2017-06-05 | 2017-06-05 | PR-Z3-LW-LS-93-0070 FS+120d | 57.2d | 0d |  |  | OK | 1.2.6.10 | PROC | PROC |
| PR-Z3-LW-LS-93-0090 |  | Complete Material Delivery - Palm Trees |  | 85d | 2017-06-05 | 2017-09-21 | PR-Z3-LW-LS-93-0080 | 103.2d | 0d | Palm Trees [686 ea] | 1,366,816.13 | OK | 1.2.6.10 | PROC | PROC |
| PR-Z3-LW-LS-93-0100 |  | NMR 603 - Palm Trees |  | 8d | 2017-09-21 | 2017-10-02 | PR-Z3-LW-LS-93-0090 | 103.2d | 21d |  |  | OK | 1.2.6.10 | PROC | PROC |
|  | 2 | **Washing Tonia Robusta - Trees** |  |  | 2016-11-16 | 2017-09-25 |  |  |  |  |  |  |  |  |  |
| PR-Z3-LW-LS-94-0010 |  | RFQ - Washing Tonia Robusta (Trees) |  | 5.6d | 2016-11-16 | 2016-11-22 | PROC-GE-GE-GE-0010 FS+81d | 109.2d | 0d |  |  | OK | 1.2.6.10 | PROC | PROC |
| PR-Z3-LW-LS-94-0020 |  | Material Submittal - Washing Tonia Robusta (Trees) |  | 8d | 2016-11-22 | 2016-12-01 | PR-Z3-LW-LS-94-0010 | 109.2d | 0d |  |  | OK | 1.2.6.10 | PROC | PROC |
| PR-Z3-LW-LS-94-0030 |  | Material Approval - Washing Tonia Robusta (Trees) |  | 11.2d | 2016-12-01 | 2016-12-14 | PR-Z3-LW-LS-94-0020 | 109.2d | 0d |  |  | OK | 1.2.6.10 | PROC | PROC |
| PR-Z3-LW-LS-94-0040 |  | Technical Evaluation - Washing Tonia Robusta (Trees) |  | 8d | 2016-12-15 | 2016-12-24 | PR-Z3-LW-LS-94-0030 | 109.2d | 0d |  |  | OK | 1.2.6.10 | PROC | PROC |
| PR-Z3-LW-LS-94-0050 |  | PO - Washing Tonia Robusta (Trees) |  | 11.2d | 2016-12-25 | 2017-01-07 | PR-Z3-LW-LS-94-0040 | 109.2d | 0d |  |  | OK | 1.2.6.10 | PROC | PROC |
| PR-Z3-LW-LS-94-0060 |  | NMR 601 - Washing Tonia Robusta (Trees) |  | 4.8d | 2017-01-07 | 2017-01-11 | PR-Z3-LW-LS-94-0050 | 109.2d | 0d |  |  | OK | 1.2.6.10 | PROC | PROC |
| PR-Z3-LW-LS-94-0070 |  | NMR 602 - Washing Tonia Robusta (Trees) |  | 4.8d | 2017-01-12 | 2017-01-17 | PR-Z3-LW-LS-94-0060 | 109.2d | 0d |  |  | OK | 1.2.6.10 | PROC | PROC |
| PR-Z3-LW-LS-94-0080 |  | Start of Material Delivery - Washing Tonia Robusta (Trees) | milestone | 0d | 2017-07-16 | 2017-07-16 | PR-Z3-LW-LS-94-0070 FS+150d | 109.2d | 0d |  |  | OK | 1.2.6.10 | PROC | PROC |
| PR-Z3-LW-LS-94-0090 |  | Complete Material Delivery - Washing Tonia Robusta (Trees) |  | 48d | 2017-07-16 | 2017-09-14 | PR-Z3-LW-LS-94-0080 | 109.2d | 0d | Washing Tonia Robusta - Trees [47 ea] | 163,878.46 | OK | 1.2.6.10 | PROC | PROC |
| PR-Z3-LW-LS-94-0100 |  | NMR 603 - Washing Tonia Robusta (Trees) |  | 8d | 2017-09-14 | 2017-09-25 | PR-Z3-LW-LS-94-0090 | 109.2d | 27d |  |  | OK | 1.2.6.10 | PROC | PROC |

Notes:
- PR-Z3-LW-LS-93-0090: Expenses: (New Expense Item) 1366816
- PR-Z3-LW-LS-94-0090: Expenses: (New Expense Item) 163878

| ID | WBS | Activity | Type | Duration | Start | Finish | Predecessors | Total float | Free float | Resources | Cost | Wajid | RPI_P2 - BOQ ITEMS | RPI_P2 - PROCUREMENT | RPI_P2 - PHASE |
| --- | --- | --- | --- | --- | --- | --- | --- | --- | --- | --- | --- | --- | --- | --- | --- |
|  | 3 | **Jacaranda - Trees** |  |  | 2016-11-16 | 2017-10-03 |  |  |  |  |  |  |  |  |  |
| PR-Z3-LW-LS-95-0010 |  | RFQ - Jacaranda (Trees) |  | 5.6d | 2016-11-16 | 2016-11-22 | PROC-GE-GE-GE-0010 FS+81d | 102.2d | 0d |  |  | OK | 1.2.6.10 | PROC | PROC |
| PR-Z3-LW-LS-95-0020 |  | Material Submittal - Jacaranda (Trees) |  | 8d | 2016-11-22 | 2016-12-01 | PR-Z3-LW-LS-95-0010 | 102.2d | 0d |  |  | OK | 1.2.6.10 | PROC | PROC |
| PR-Z3-LW-LS-95-0030 |  | Material Approval - Jacaranda (Trees) |  | 11.2d | 2016-12-01 | 2016-12-14 | PR-Z3-LW-LS-95-0020 | 102.2d | 0d |  |  | OK | 1.2.6.10 | PROC | PROC |
| PR-Z3-LW-LS-95-0040 |  | Technical Evaluation - Jacaranda (Trees) |  | 8d | 2016-12-15 | 2016-12-24 | PR-Z3-LW-LS-95-0030 | 102.2d | 0d |  |  | OK | 1.2.6.10 | PROC | PROC |
| PR-Z3-LW-LS-95-0050 |  | PO - Jacaranda (Trees) |  | 11.2d | 2016-12-25 | 2017-01-07 | PR-Z3-LW-LS-95-0040 | 102.2d | 0d |  |  | OK | 1.2.6.10 | PROC | PROC |
| PR-Z3-LW-LS-95-0060 |  | NMR 601 - Jacaranda (Trees) |  | 4.8d | 2017-01-07 | 2017-01-11 | PR-Z3-LW-LS-95-0050 | 102.2d | 0d |  |  | OK | 1.2.6.10 | PROC | PROC |
| PR-Z3-LW-LS-95-0070 |  | NMR 602 - Jacaranda (Trees) |  | 4.8d | 2017-01-12 | 2017-01-17 | PR-Z3-LW-LS-95-0060 | 102.2d | 0d |  |  | OK | 1.2.6.10 | PROC | PROC |
| PR-Z3-LW-LS-95-0080 |  | Start of Material Delivery - Jacaranda (Trees) | milestone | 0d | 2017-07-10 | 2017-07-10 | PR-Z3-LW-LS-95-0070 FS+145d | 102.2d | 0d |  |  | OK | 1.2.6.10 | PROC | PROC |
| PR-Z3-LW-LS-95-0090 |  | Complete Material Delivery - Jacaranda (Trees) |  | 60d | 2017-07-10 | 2017-09-24 | PR-Z3-LW-LS-95-0080 | 102.2d | 0d | Jacaranda - Trees [168 ea] | 267,784.38 | OK | 1.2.6.10 | PROC | PROC |
| PR-Z3-LW-LS-95-0100 |  | NMR 603 - Jacaranda (Trees) |  | 8d | 2017-09-24 | 2017-10-03 | PR-Z3-LW-LS-95-0090 | 102.2d | 20d |  |  | OK | 1.2.6.10 | PROC | PROC |
|  | 4 | **Cassia Fistula - Trees** |  |  | 2016-11-16 | 2017-10-09 |  |  |  |  |  |  |  |  |  |
| PR-Z3-LW-LS-96-0010 |  | RFQ - Cassia Fistula (Trees) |  | 5.6d | 2016-11-16 | 2016-11-22 | PROC-GE-GE-GE-0010 FS+81d | 97.2d | 0d |  |  | OK | 1.2.6.10 | PROC | PROC |
| PR-Z3-LW-LS-96-0020 |  | Material Submittal - Cassia Fistula (Trees) |  | 8d | 2016-11-22 | 2016-12-01 | PR-Z3-LW-LS-96-0010 | 97.2d | 0d |  |  | OK | 1.2.6.10 | PROC | PROC |
| PR-Z3-LW-LS-96-0030 |  | Material Approval - Cassia Fistula (Trees) |  | 11.2d | 2016-12-01 | 2016-12-14 | PR-Z3-LW-LS-96-0020 | 97.2d | 0d |  |  | OK | 1.2.6.10 | PROC | PROC |
| PR-Z3-LW-LS-96-0040 |  | Technical Evaluation - Cassia Fistula (Trees) |  | 8d | 2016-12-15 | 2016-12-24 | PR-Z3-LW-LS-96-0030 | 97.2d | 0d |  |  | OK | 1.2.6.10 | PROC | PROC |
| PR-Z3-LW-LS-96-0050 |  | PO - Cassia Fistula (Trees) |  | 11.2d | 2016-12-25 | 2017-01-07 | PR-Z3-LW-LS-96-0040 | 97.2d | 0d |  |  | OK | 1.2.6.10 | PROC | PROC |
| PR-Z3-LW-LS-96-0060 |  | NMR 601 - Cassia Fistula (Trees) |  | 4.8d | 2017-01-07 | 2017-01-11 | PR-Z3-LW-LS-96-0050 | 97.2d | 0d |  |  | OK | 1.2.6.10 | PROC | PROC |
| PR-Z3-LW-LS-96-0070 |  | NMR 602 - Cassia Fistula (Trees) |  | 4.8d | 2017-01-12 | 2017-01-17 | PR-Z3-LW-LS-96-0060 | 97.2d | 0d |  |  | OK | 1.2.6.10 | PROC | PROC |
| PR-Z3-LW-LS-96-0080 |  | Start of Material Delivery - Cassia Fistula (Trees) | milestone | 0d | 2017-07-16 | 2017-07-16 | PR-Z3-LW-LS-96-0070 FS+150d | 97.2d | 0d |  |  | OK | 1.2.6.10 | PROC | PROC |
| PR-Z3-LW-LS-96-0090 |  | Complete Material Delivery - Cassia Fistula (Trees) |  | 60d | 2017-07-16 | 2017-09-30 | PR-Z3-LW-LS-96-0080 | 97.2d | 0d | Cassia Fistula - Trees [107 ea] | 319,787.15 | OK | 1.2.6.10 | PROC | PROC |
| PR-Z3-LW-LS-96-0100 |  | NMR 603 - Cassia Fistula (Trees) |  | 8d | 2017-09-30 | 2017-10-09 | PR-Z3-LW-LS-96-0090 | 97.2d | 15d |  |  | OK | 1.2.6.10 | PROC | PROC |
|  | 5 | **Albizia Julibrissin - Trees** |  |  | 2016-11-16 | 2017-10-15 |  |  |  |  |  |  |  |  |  |
| PR-Z3-LW-LS-97-0010 |  | RFQ - Albizia Julibrissin (Trees) |  | 5.6d | 2016-11-16 | 2016-11-22 | PROC-GE-GE-GE-0010 FS+81d | 92.2d | 0d |  |  | OK | 1.2.6.10 | PROC | PROC |
| PR-Z3-LW-LS-97-0020 |  | Material Submittal - Albizia Julibrissin (Trees) |  | 8d | 2016-11-22 | 2016-12-01 | PR-Z3-LW-LS-97-0010 | 92.2d | 0d |  |  | OK | 1.2.6.10 | PROC | PROC |
| PR-Z3-LW-LS-97-0030 |  | Material Approval - Albizia Julibrissin (Trees) |  | 11.2d | 2016-12-01 | 2016-12-14 | PR-Z3-LW-LS-97-0020 | 92.2d | 0d |  |  | OK | 1.2.6.10 | PROC | PROC |
| PR-Z3-LW-LS-97-0040 |  | Technical Evaluation - Albizia Julibrissin (Trees) |  | 8d | 2016-12-15 | 2016-12-24 | PR-Z3-LW-LS-97-0030 | 92.2d | 0d |  |  | OK | 1.2.6.10 | PROC | PROC |
| PR-Z3-LW-LS-97-0050 |  | PO - Albizia Julibrissin (Trees) |  | 11.2d | 2016-12-25 | 2017-01-07 | PR-Z3-LW-LS-97-0040 | 92.2d | 0d |  |  | OK | 1.2.6.10 | PROC | PROC |
| PR-Z3-LW-LS-97-0060 |  | NMR 601 - Albizia Julibrissin (Trees) |  | 4.8d | 2017-01-07 | 2017-01-11 | PR-Z3-LW-LS-97-0050 | 92.2d | 0d |  |  | OK | 1.2.6.10 | PROC | PROC |
| PR-Z3-LW-LS-97-0070 |  | NMR 602 - Albizia Julibrissin (Trees) |  | 4.8d | 2017-01-12 | 2017-01-17 | PR-Z3-LW-LS-97-0060 | 92.2d | 0d |  |  | OK | 1.2.6.10 | PROC | PROC |
| PR-Z3-LW-LS-97-0080 |  | Start of Material Delivery - Albizia Julibrissin (Trees) | milestone | 0d | 2017-07-22 | 2017-07-22 | PR-Z3-LW-LS-97-0070 FS+155d | 92.2d | 0d |  |  | OK | 1.2.6.10 | PROC | PROC |
| PR-Z3-LW-LS-97-0090 |  | Complete Material Delivery - Albizia Julibrissin (Trees) |  | 60d | 2017-07-22 | 2017-10-05 | PR-Z3-LW-LS-97-0080 | 92.2d | 0d | Albizia Julibrissin - Trees [239 ea] | 404,764.86 | OK | 1.2.6.10 | PROC | PROC |
| PR-Z3-LW-LS-97-0100 |  | NMR 603 - Albizia Julibrissin (Trees) |  | 8d | 2017-10-05 | 2017-10-15 | PR-Z3-LW-LS-97-0090 | 92.2d | 10d |  |  | OK | 1.2.6.10 | PROC | PROC |

Notes:
- PR-Z3-LW-LS-95-0090: Expenses: (New Expense Item) 267784
- PR-Z3-LW-LS-96-0090: Expenses: (New Expense Item) 319787
- PR-Z3-LW-LS-97-0090: Expenses: (New Expense Item) 404765

| ID | WBS | Activity | Type | Duration | Start | Finish | Predecessors | Total float | Free float | Resources | Cost | Wajid | RPI_P2 - BOQ ITEMS | RPI_P2 - PROCUREMENT | RPI_P2 - PHASE |
| --- | --- | --- | --- | --- | --- | --- | --- | --- | --- | --- | --- | --- | --- | --- | --- |
|  | 6 | **Chamaerops Humilis - Trees** |  |  | 2016-11-16 | 2017-10-19 |  |  |  |  |  |  |  |  |  |
| PR-Z3-LW-LS-98-0010 |  | RFQ - Chamaerops Humilis (Trees) |  | 5.6d | 2016-11-16 | 2016-11-22 | PROC-GE-GE-GE-0010 FS+81d | 88.2d | 0d |  |  | OK | 1.2.6.10 | PROC | PROC |
| PR-Z3-LW-LS-98-0020 |  | Material Submittal - Chamaerops Humilis (Trees) |  | 8d | 2016-11-22 | 2016-12-01 | PR-Z3-LW-LS-98-0010 | 88.2d | 0d |  |  | OK | 1.2.6.10 | PROC | PROC |
| PR-Z3-LW-LS-98-0030 |  | Material Approval - Chamaerops Humilis (Trees) |  | 11.2d | 2016-12-01 | 2016-12-14 | PR-Z3-LW-LS-98-0020 | 88.2d | 0d |  |  | OK | 1.2.6.10 | PROC | PROC |
| PR-Z3-LW-LS-98-0040 |  | Technical Evaluation - Chamaerops Humilis (Trees) |  | 8d | 2016-12-15 | 2016-12-24 | PR-Z3-LW-LS-98-0030 | 88.2d | 0d |  |  | OK | 1.2.6.10 | PROC | PROC |
| PR-Z3-LW-LS-98-0050 |  | PO - Chamaerops Humilis (Trees) |  | 11.2d | 2016-12-25 | 2017-01-07 | PR-Z3-LW-LS-98-0040 | 88.2d | 0d |  |  | OK | 1.2.6.10 | PROC | PROC |
| PR-Z3-LW-LS-98-0060 |  | NMR 601 - Chamaerops Humilis (Trees) |  | 4.8d | 2017-01-07 | 2017-01-11 | PR-Z3-LW-LS-98-0050 | 88.2d | 0d |  |  | OK | 1.2.6.10 | PROC | PROC |
| PR-Z3-LW-LS-98-0070 |  | NMR 602 - Chamaerops Humilis (Trees) |  | 4.8d | 2017-01-12 | 2017-01-17 | PR-Z3-LW-LS-98-0060 | 88.2d | 0d |  |  | OK | 1.2.6.10 | PROC | PROC |
| PR-Z3-LW-LS-98-0080 |  | Start of Material Delivery - Chamaerops Humilis (Trees) | milestone | 0d | 2017-07-10 | 2017-07-10 | PR-Z3-LW-LS-98-0070 FS+145d | 88.2d | 0d |  |  | OK | 1.2.6.10 | PROC | PROC |
| PR-Z3-LW-LS-98-0090 |  | Complete Material Delivery - Chamaerops Humilis (Trees) |  | 74d | 2017-07-10 | 2017-10-10 | PR-Z3-LW-LS-98-0080 | 88.2d | 0d | Chamaerops Humilis - Trees [315 ea] | 784,524.56 | OK | 1.2.6.10 | PROC | PROC |
| PR-Z3-LW-LS-98-0100 |  | NMR 603 - Chamaerops Humilis (Trees) |  | 8d | 2017-10-10 | 2017-10-19 | PR-Z3-LW-LS-98-0090 | 88.2d | 6d |  |  | OK | 1.2.6.10 | PROC | PROC |
|  | 7 | **Cycas Revolute - Plant** |  |  | 2016-11-16 | 2017-10-10 |  |  |  |  |  |  |  |  |  |
| PR-Z3-LW-LS-99-0010 |  | RFQ - Cycas Revolute (Plant) |  | 5.6d | 2016-11-16 | 2016-11-22 | PROC-GE-GE-GE-0010 FS+81d | 96.2d | 0d |  |  | OK | 1.2.6.10 | PROC | PROC |
| PR-Z3-LW-LS-99-0020 |  | Material Submittal - Cycas Revolute (Plant) |  | 8d | 2016-11-22 | 2016-12-01 | PR-Z3-LW-LS-99-0010 | 96.2d | 0d |  |  | OK | 1.2.6.10 | PROC | PROC |
| PR-Z3-LW-LS-99-0030 |  | Material Approval - Cycas Revolute (Plant) |  | 11.2d | 2016-12-01 | 2016-12-14 | PR-Z3-LW-LS-99-0020 | 96.2d | 0d |  |  | OK | 1.2.6.10 | PROC | PROC |
| PR-Z3-LW-LS-99-0040 |  | Technical Evaluation - Cycas Revolute (Plant) |  | 8d | 2016-12-15 | 2016-12-24 | PR-Z3-LW-LS-99-0030 | 96.2d | 0d |  |  | OK | 1.2.6.10 | PROC | PROC |
| PR-Z3-LW-LS-99-0050 |  | PO - Cycas Revolute (Plant) |  | 11.2d | 2016-12-25 | 2017-01-07 | PR-Z3-LW-LS-99-0040 | 96.2d | 0d |  |  | OK | 1.2.6.10 | PROC | PROC |
| PR-Z3-LW-LS-99-0060 |  | NMR 601 - Cycas Revolute (Plant) |  | 4.8d | 2017-01-07 | 2017-01-11 | PR-Z3-LW-LS-99-0050 | 96.2d | 0d |  |  | OK | 1.2.6.10 | PROC | PROC |
| PR-Z3-LW-LS-99-0070 |  | NMR 602 - Cycas Revolute (Plant) |  | 4.8d | 2017-01-12 | 2017-01-17 | PR-Z3-LW-LS-99-0060 | 96.2d | 0d |  |  | OK | 1.2.6.10 | PROC | PROC |
| PR-Z3-LW-LS-99-0080 |  | Start of Material Delivery - Cycas Revolute (Plant) | milestone | 0d | 2017-07-31 | 2017-07-31 | PR-Z3-LW-LS-99-0070 FS+163d | 96.2d | 0d |  |  | OK | 1.2.6.10 | PROC | PROC |
| PR-Z3-LW-LS-99-0090 |  | Complete Material Delivery - Cycas Revolute (Plant) |  | 48d | 2017-07-31 | 2017-10-01 | PR-Z3-LW-LS-99-0080 | 96.2d | 0d | Cycas Revolute - Plant [57 ea] | 141,961.59 | OK | 1.2.6.10 | PROC | PROC |
| PR-Z3-LW-LS-99-0100 |  | NMR 603 - Cycas Revolute (Plant) |  | 8d | 2017-10-01 | 2017-10-10 | PR-Z3-LW-LS-99-0090 | 96.2d | 14d |  |  | OK | 1.2.6.10 | PROC | PROC |
|  | 8 | **Shurbs** |  |  | 2016-11-16 | 2017-10-12 |  |  |  |  |  |  |  |  |  |
| PR-Z3-LW-LS-100-0010 |  | RFQ - Shurbs |  | 5.6d | 2016-11-16 | 2016-11-22 | PROC-GE-GE-GE-0010 FS+81d | 94.2d | 0d |  |  | OK | 1.2.6.10 | PROC | PROC |
| PR-Z3-LW-LS-100-0020 |  | Material Submittal - Shurbs |  | 8d | 2016-11-22 | 2016-12-01 | PR-Z3-LW-LS-100-0010 | 94.2d | 0d |  |  | OK | 1.2.6.10 | PROC | PROC |
| PR-Z3-LW-LS-100-0030 |  | Material Approval - Shurbs |  | 11.2d | 2016-12-01 | 2016-12-14 | PR-Z3-LW-LS-100-0020 | 94.2d | 0d |  |  | OK | 1.2.6.10 | PROC | PROC |
| PR-Z3-LW-LS-100-0040 |  | Technical Evaluation - Shurbs |  | 8d | 2016-12-15 | 2016-12-24 | PR-Z3-LW-LS-100-0030 | 94.2d | 0d |  |  | OK | 1.2.6.10 | PROC | PROC |
| PR-Z3-LW-LS-100-0050 |  | PO - Shurbs |  | 11.2d | 2016-12-25 | 2017-01-07 | PR-Z3-LW-LS-100-0040 | 94.2d | 0d |  |  | OK | 1.2.6.10 | PROC | PROC |
| PR-Z3-LW-LS-100-0060 |  | NMR 601 - Shurbs |  | 4.8d | 2017-01-07 | 2017-01-11 | PR-Z3-LW-LS-100-0050 | 94.2d | 0d |  |  | OK | 1.2.6.10 | PROC | PROC |
| PR-Z3-LW-LS-100-0070 |  | NMR 602 - Shurbs |  | 4.8d | 2017-01-12 | 2017-01-17 | PR-Z3-LW-LS-100-0060 | 94.2d | 0d |  |  | OK | 1.2.6.10 | PROC | PROC |
| PR-Z3-LW-LS-100-0080 |  | Start of Material Delivery - Shurbs | milestone | 0d | 2017-08-02 | 2017-08-02 | PR-Z3-LW-LS-100-0070 FS+165d | 94.2d | 0d |  |  | OK | 1.2.6.10 | PROC | PROC |
| PR-Z3-LW-LS-100-0090 |  | Complete Material Delivery - Shurbs |  | 48d | 2017-08-02 | 2017-10-03 | PR-Z3-LW-LS-100-0080 | 94.2d | 0d | Shurbs (m2) [1273 Sqm]; Shurbs [1815 ea] | 275,525.02 | OK | 1.2.6.10 | PROC | PROC |
| PR-Z3-LW-LS-100-0100 |  | NMR 603 - Shurbs |  | 8d | 2017-10-03 | 2017-10-12 | PR-Z3-LW-LS-100-0090 | 94.2d | 12d |  |  | OK | 1.2.6.10 | PROC | PROC |

Notes:
- PR-Z3-LW-LS-98-0090: Expenses: (New Expense Item) 784525
- PR-Z3-LW-LS-99-0090: Expenses: (New Expense Item) 141962
- PR-Z3-LW-LS-100-0090: Expenses: (New Expense Item) 275525

| ID | WBS | Activity | Type | Duration | Start | Finish | Predecessors | Total float | Free float | Resources | Cost | Wajid | RPI_P2 - BOQ ITEMS | RPI_P2 - PROCUREMENT | RPI_P2 - PHASE |
| --- | --- | --- | --- | --- | --- | --- | --- | --- | --- | --- | --- | --- | --- | --- | --- |
|  | 9 | **Ground Covers** |  |  | 2016-11-16 | 2017-10-26 |  |  |  |  |  |  |  |  |  |
| PR-Z3-LW-LS-101-0010 |  | RFQ - Ground Covers |  | 5.6d | 2016-11-16 | 2016-11-22 | PROC-GE-GE-GE-0010 FS+81d | 82.2d | 0d |  |  | OK | 1.2.6.10 | PROC | PROC |
| PR-Z3-LW-LS-101-0020 |  | Material Submittal - Ground Covers |  | 8d | 2016-11-22 | 2016-12-01 | PR-Z3-LW-LS-101-0010 | 82.2d | 0d |  |  | OK | 1.2.6.10 | PROC | PROC |
| PR-Z3-LW-LS-101-0030 |  | Material Approval - Ground Covers |  | 11.2d | 2016-12-01 | 2016-12-14 | PR-Z3-LW-LS-101-0020 | 82.2d | 0d |  |  | OK | 1.2.6.10 | PROC | PROC |
| PR-Z3-LW-LS-101-0040 |  | Technical Evaluation - Ground Covers |  | 8d | 2016-12-15 | 2016-12-24 | PR-Z3-LW-LS-101-0030 | 82.2d | 0d |  |  | OK | 1.2.6.10 | PROC | PROC |
| PR-Z3-LW-LS-101-0050 |  | PO - Ground Covers |  | 11.2d | 2016-12-25 | 2017-01-07 | PR-Z3-LW-LS-101-0040 | 82.2d | 0d |  |  | OK | 1.2.6.10 | PROC | PROC |
| PR-Z3-LW-LS-101-0060 |  | NMR 601 - Ground Covers |  | 4.8d | 2017-01-07 | 2017-01-11 | PR-Z3-LW-LS-101-0050 | 82.2d | 0d |  |  | OK | 1.2.6.10 | PROC | PROC |
| PR-Z3-LW-LS-101-0070 |  | NMR 602 - Ground Covers |  | 4.8d | 2017-01-12 | 2017-01-17 | PR-Z3-LW-LS-101-0060 | 82.2d | 0d |  |  | OK | 1.2.6.10 | PROC | PROC |
| PR-Z3-LW-LS-101-0080 |  | Start of Material Delivery - Ground Covers | milestone | 0d | 2017-08-02 | 2017-08-02 | PR-Z3-LW-LS-101-0070 FS+165d | 82.2d | 0d |  |  | OK | 1.2.6.10 | PROC | PROC |
| PR-Z3-LW-LS-101-0090 |  | Complete Material Delivery - Ground Covers |  | 60d | 2017-08-02 | 2017-10-17 | PR-Z3-LW-LS-101-0080 | 82.2d | 0d | Ground Covers [892 ea]; Ground Covers (m2) [33884 Sqm] | 3,648,841.15 | OK | 1.2.6.10 | PROC | PROC |
| PR-Z3-LW-LS-101-0100 |  | NMR 603 - Ground Covers |  | 8d | 2017-10-17 | 2017-10-26 | PR-Z3-LW-LS-101-0090 | 82.2d | 0d |  |  | OK | 1.2.6.10 | PROC | PROC |
|  | 10 | **Gravel & Gravel Mulch** |  |  | 2016-11-09 | 2017-08-14 |  |  |  |  |  |  |  |  |  |
| PR-Z3-LW-LS-102-0010 |  | RFQ - Gravel and Gravel Mulch |  | 5.6d | 2016-11-09 | 2016-11-15 | PROC-GE-GE-GE-0010 FS+75d | 140.2d | 0d |  |  | OK | 1.2.6.10 | PROC | PROC |
| PR-Z3-LW-LS-102-0020 |  | Material Submittal - Gravel and Gravel Mulch |  | 8d | 2016-11-15 | 2016-11-24 | PR-Z3-LW-LS-102-0010 | 140.2d | 0d |  |  | OK | 1.2.6.10 | PROC | PROC |
| PR-Z3-LW-LS-102-0030 |  | Material Approval - Gravel and Gravel Mulch |  | 11.2d | 2016-11-24 | 2016-12-07 | PR-Z3-LW-LS-102-0020 | 140.2d | 0d |  |  | OK | 1.2.6.10 | PROC | PROC |
| PR-Z3-LW-LS-102-0040 |  | Technical Evaluation - Gravel and Gravel Mulch |  | 8d | 2016-12-08 | 2016-12-17 | PR-Z3-LW-LS-102-0030 | 140.2d | 0d |  |  | OK | 1.2.6.10 | PROC | PROC |
| PR-Z3-LW-LS-102-0050 |  | PO - Gravel and Gravel Mulch |  | 11.2d | 2016-12-18 | 2016-12-31 | PR-Z3-LW-LS-102-0040 | 140.2d | 0d |  |  | OK | 1.2.6.10 | PROC | PROC |
| PR-Z3-LW-LS-102-0060 |  | NMR 601 - Gravel and Gravel Mulch |  | 4.8d | 2016-12-31 | 2017-01-04 | PR-Z3-LW-LS-102-0050 | 140.2d | 0d |  |  | OK | 1.2.6.10 | PROC | PROC |
| PR-Z3-LW-LS-102-0070 |  | NMR 602 - Gravel and Gravel Mulch |  | 4.8d | 2017-01-05 | 2017-01-10 | PR-Z3-LW-LS-102-0060 | 140.2d | 0d |  |  | OK | 1.2.6.10 | PROC | PROC |
| PR-Z3-LW-LS-102-0080 |  | Start of Material Delivery - Gravel and Gravel Mulch | milestone | 0d | 2017-06-05 | 2017-06-05 | PR-Z3-LW-LS-102-0070 FS+125d | 140.2d | 0d |  |  | OK | 1.2.6.10 | PROC | PROC |
| PR-Z3-LW-LS-102-0090 |  | Complete Material Delivery - Gravel and Gravel Mulch |  | 48d | 2017-06-05 | 2017-08-05 | PR-Z3-LW-LS-102-0080 | 140.2d | 0d | Gravel & Gravel Mulch, Gravel N0.4 PEA [2803 Sqm] | 156,462.59 | OK | 1.2.6.10 | PROC | PROC |
| PR-Z3-LW-LS-102-0100 |  | NMR 603 - Gravel and Gravel Mulch |  | 8d | 2017-08-05 | 2017-08-14 | PR-Z3-LW-LS-102-0090 | 140.2d | 58d |  |  | OK | 1.2.6.10 | PROC | PROC |
|  | 11 | **Play Ground Sand** |  |  | 2016-11-09 | 2017-10-11 |  |  |  |  |  |  |  |  |  |
| PR-Z3-LW-LS-103-0010 |  | RFQ - Play Ground Sand |  | 5.6d | 2016-11-09 | 2016-11-15 | PROC-GE-GE-GE-0010 FS+75d | 95.2d | 0d |  |  | OK | 1.2.6.10 | PROC | PROC |
| PR-Z3-LW-LS-103-0020 |  | Material Submittal - Play Ground Sand |  | 8d | 2016-11-15 | 2016-11-24 | PR-Z3-LW-LS-103-0010 | 95.2d | 0d |  |  | OK | 1.2.6.10 | PROC | PROC |
| PR-Z3-LW-LS-103-0030 |  | Material Approval - Play Ground Sand |  | 11.2d | 2016-11-24 | 2016-12-07 | PR-Z3-LW-LS-103-0020 | 95.2d | 0d |  |  | OK | 1.2.6.10 | PROC | PROC |
| PR-Z3-LW-LS-103-0040 |  | Technical Evaluation - Play Ground Sand |  | 8d | 2016-12-08 | 2016-12-17 | PR-Z3-LW-LS-103-0030 | 95.2d | 0d |  |  | OK | 1.2.6.10 | PROC | PROC |
| PR-Z3-LW-LS-103-0050 |  | PO - Play Ground Sand |  | 11.2d | 2016-12-18 | 2016-12-31 | PR-Z3-LW-LS-103-0040 | 95.2d | 0d |  |  | OK | 1.2.6.10 | PROC | PROC |
| PR-Z3-LW-LS-103-0060 |  | NMR 601 - Play Ground Sand |  | 4.8d | 2016-12-31 | 2017-01-04 | PR-Z3-LW-LS-103-0050 | 95.2d | 0d |  |  | OK | 1.2.6.10 | PROC | PROC |
| PR-Z3-LW-LS-103-0070 |  | NMR 602 - Play Ground Sand |  | 4.8d | 2017-01-05 | 2017-01-10 | PR-Z3-LW-LS-103-0060 | 95.2d | 0d |  |  | OK | 1.2.6.10 | PROC | PROC |
| PR-Z3-LW-LS-103-0080 |  | Start of Material Delivery - Play Ground Sand | milestone | 0d | 2017-08-01 | 2017-08-01 | PR-Z3-LW-LS-103-0070 FS+170d | 95.2d | 0d |  |  | OK | 1.2.6.10 | PROC | PROC |
| PR-Z3-LW-LS-103-0090 |  | Complete Material Delivery - Play Ground Sand |  | 48d | 2017-08-01 | 2017-10-02 | PR-Z3-LW-LS-103-0080 | 95.2d | 0d | Play Ground Sand & Sand Fill [2594 Sqm] | 299,514.04 | OK | 1.2.6.10 | PROC | PROC |
| PR-Z3-LW-LS-103-0100 |  | NMR 603 - Play Ground Sand |  | 8d | 2017-10-02 | 2017-10-11 | PR-Z3-LW-LS-103-0090 | 95.2d | 13d |  |  | OK | 1.2.6.10 | PROC | PROC |

Notes:
- PR-Z3-LW-LS-101-0090: Expenses: (New Expense Item) 3648841
- PR-Z3-LW-LS-102-0090: Expenses: (New Expense Item) 156463
- PR-Z3-LW-LS-103-0090: Expenses: (New Expense Item) 299514

| ID | WBS | Activity | Type | Duration | Start | Finish | Predecessors | Total float | Free float | Resources | Cost | Wajid | RPI_P2 - BOQ ITEMS | RPI_P2 - PROCUREMENT | RPI_P2 - PHASE |
| --- | --- | --- | --- | --- | --- | --- | --- | --- | --- | --- | --- | --- | --- | --- | --- |
|  | 2 | **All Concrete Tiles, Furniture and Hardscape Materials** |  |  | 2016-08-23 | 2017-07-29 |  |  |  |  |  |  |  |  |  |
|  | 1 | **Polyethene Sheet (Pedestrian Walkway)** |  |  | 2016-09-01 | 2017-01-11 |  |  |  |  |  |  |  |  |  |
| PR-Z3-LW-LS-104-0010 |  | RFQ - Polyethene Sheet |  | 5.6d | 2016-09-01 | 2016-09-07 | PR-Z3-CW-CW-22-0010 SS, PROC-GE-GE-GE-0010 FS+3d | 313.8d | 0d |  |  | OK | 1.2.6.20 | PROC | PROC |
| PR-Z3-LW-LS-104-0020 |  | Material Submittal - Polyethene Sheet |  | 8d | 2016-09-07 | 2016-09-21 | PR-Z3-LW-LS-104-0010 | 313.8d | 0d |  |  | OK | 1.2.6.20 | PROC | PROC |
| PR-Z3-LW-LS-104-0030 |  | Material Approval - Polyethene Sheet |  | 11.2d | 2016-09-21 | 2016-10-04 | PR-Z3-LW-LS-104-0020 | 313.8d | 0d |  |  | OK | 1.2.6.20 | PROC | PROC |
| PR-Z3-LW-LS-104-0040 |  | Technical Evaluation - Polyethene Sheet |  | 8d | 2016-10-05 | 2016-10-13 | PR-Z3-LW-LS-104-0030 | 313.8d | 0d |  |  | OK | 1.2.6.20 | PROC | PROC |
| PR-Z3-LW-LS-104-0050 |  | PO - Polyethene Sheet |  | 11.2d | 2016-10-15 | 2016-10-27 | PR-Z3-LW-LS-104-0040 | 313.8d | 0d |  |  | OK | 1.2.6.20 | PROC | PROC |
| PR-Z3-LW-LS-104-0060 |  | NMR 601 - Polyethene Sheet |  | 4.8d | 2016-10-27 | 2016-11-01 | PR-Z3-LW-LS-104-0050 | 313.8d | 0d |  |  | OK | 1.2.6.20 | PROC | PROC |
| PR-Z3-LW-LS-104-0070 |  | NMR 602 - Polyethene Sheet |  | 4.8d | 2016-11-02 | 2016-11-07 | PR-Z3-LW-LS-104-0060 | 313.8d | 0d |  |  | OK | 1.2.6.20 | PROC | PROC |
| PR-Z3-LW-LS-104-0080 |  | Start of Material Delivery - Polyethene Sheet | milestone | 0d | 2016-11-07 | 2016-11-07 | PR-Z3-LW-LS-104-0070 | 313.8d | 0d |  |  | OK | 1.2.6.20 | PROC | PROC |
| PR-Z3-LW-LS-104-0090 |  | Complete Material Delivery - Polyethene Sheet |  | 48d | 2016-11-07 | 2017-01-02 | PR-Z3-LW-LS-104-0080 | 320.2d | 0d | Polyethene Sheet [21085 Sqm] | 77,270.99 | OK | 1.2.6.20 | PROC | PROC |
| PR-Z3-LW-LS-104-0100 |  | NMR 603 - Polyethene Sheet |  | 8d | 2017-01-02 | 2017-01-11 | PR-Z3-LW-LS-104-0090 | 320.2d | 238d |  |  | OK | 1.2.6.20 | PROC | PROC |
|  | 3 | **Aggregate Base Course (Pedestrian Walkway)** |  |  | 2016-09-18 | 2017-03-11 |  |  |  |  |  |  |  |  |  |
| PR-Z3-LW-LS-105-0010 |  | RFQ - Aggregate Base Course |  | 5.6d | 2016-09-18 | 2016-09-24 | PROC-GE-GE-GE-0010 FS+30d | 232.6d | 0d |  |  | OK | 1.2.6.20 | PROC | PROC |
| PR-Z3-LW-LS-105-0020 |  | Material Submittal - Aggregate Base Course |  | 8d | 2016-09-24 | 2016-10-03 | PR-Z3-LW-LS-105-0010 | 232.6d | 0d |  |  | OK | 1.2.6.20 | PROC | PROC |
| PR-Z3-LW-LS-105-0030 |  | Material Approval - Aggregate Base Course |  | 11.2d | 2016-10-03 | 2016-10-16 | PR-Z3-LW-LS-105-0020 | 232.6d | 0d |  |  | OK | 1.2.6.20 | PROC | PROC |
| PR-Z3-LW-LS-105-0040 |  | Technical Evaluation - Aggregate Base Course |  | 8d | 2016-10-17 | 2016-10-25 | PR-Z3-LW-LS-105-0030 | 232.6d | 0d |  |  | OK | 1.2.6.20 | PROC | PROC |
| PR-Z3-LW-LS-105-0050 |  | PO - Aggregate Base Course |  | 11.2d | 2016-10-26 | 2016-11-08 | PR-Z3-LW-LS-105-0040 | 232.6d | 0d |  |  | OK | 1.2.6.20 | PROC | PROC |
| PR-Z3-LW-LS-105-0060 |  | NMR 601 - Aggregate Base Course |  | 4.8d | 2016-11-08 | 2016-11-13 | PR-Z3-LW-LS-105-0050 | 232.6d | 0d |  |  | OK | 1.2.6.20 | PROC | PROC |
| PR-Z3-LW-LS-105-0070 |  | NMR 602 - Aggregate Base Course |  | 4.8d | 2016-11-14 | 2016-11-19 | PR-Z3-LW-LS-105-0060 | 232.6d | 0d |  |  | OK | 1.2.6.20 | PROC | PROC |
| PR-Z3-LW-LS-105-0080 |  | Start of Material Delivery - Aggregate Base Course | milestone | 0d | 2016-12-07 | 2016-12-07 | PR-Z3-LW-LS-105-0070 FS+16d | 232.6d | 0d |  |  | OK | 1.2.6.20 | PROC | PROC |
| PR-Z3-LW-LS-105-0090 |  | Complete Material Delivery - Aggregate Base Course |  | 72d | 2016-12-07 | 2017-03-01 | PR-Z3-LW-LS-105-0080 | 270.2d | 0d | Aggregate Base Course [11542 Sqm] | 420,352.52 | OK | 1.2.6.20 | PROC | PROC |
| PR-Z3-LW-LS-105-0100 |  | NMR 603 - Aggregate Base Course |  | 8d | 2017-03-01 | 2017-03-11 | PR-Z3-LW-LS-105-0090 | 270.2d | 188d |  |  | OK | 1.2.6.20 | PROC | PROC |
|  | 2 | **Gravel (No. 4 PEA)** |  |  | 2016-11-16 | 2017-05-24 |  |  |  |  |  |  |  |  |  |
| PR-Z3-LW-LS-106-0010 |  | RFQ - Gravel (No. 4 PEA) |  | 6d | 2016-11-16 | 2016-11-23 | PROC-GE-GE-GE-0010 FS+81d | 206.8d | 0d |  |  | OK | 1.2.6.20 | PROC | PROC |
| PR-Z3-LW-LS-106-0020 |  | Material Submittal - Gravel (No. 4 PEA) |  | 8d | 2016-11-23 | 2016-12-03 | PR-Z3-LW-LS-106-0010 | 206.8d | 0d |  |  | OK | 1.2.6.20 | PROC | PROC |
| PR-Z3-LW-LS-106-0030 |  | Material Approval - Gravel (No. 4 PEA) |  | 11d | 2016-12-03 | 2016-12-15 | PR-Z3-LW-LS-106-0020 | 206.8d | 0d |  |  | OK | 1.2.6.20 | PROC | PROC |
| PR-Z3-LW-LS-106-0040 |  | Technical Evaluation - Gravel (No. 4 PEA) |  | 8d | 2016-12-15 | 2016-12-25 | PR-Z3-LW-LS-106-0030 | 206.8d | 0d |  |  | OK | 1.2.6.20 | PROC | PROC |
| PR-Z3-LW-LS-106-0050 |  | PO - Gravel (No. 4 PEA) |  | 11d | 2016-12-25 | 2017-01-07 | PR-Z3-LW-LS-106-0040 | 206.8d | 0d |  |  | OK | 1.2.6.20 | PROC | PROC |
| PR-Z3-LW-LS-106-0060 |  | NMR 601 - Gravel (No. 4 PEA) |  | 5d | 2017-01-07 | 2017-01-12 | PR-Z3-LW-LS-106-0050 | 206.8d | 0d |  |  | OK | 1.2.6.20 | PROC | PROC |
| PR-Z3-LW-LS-106-0070 |  | NMR 602 - Gravel (No. 4 PEA) |  | 5d | 2017-01-12 | 2017-01-18 | PR-Z3-LW-LS-106-0060 | 206.8d | 0d |  |  | OK | 1.2.6.20 | PROC | PROC |
| PR-Z3-LW-LS-106-0080 |  | Start of Material Delivery - Gravel (No. 4 PEA) | milestone | 0d | 2017-05-10 | 2017-05-10 | PR-Z3-LW-LS-106-0070 FS+96d | 206.8d | 0d |  |  | OK | 1.2.6.20 | PROC | PROC |
| PR-Z3-LW-LS-106-0090 |  | Complete Material Delivery - Gravel (No. 4 PEA) |  | 6d | 2017-05-10 | 2017-05-17 | PR-Z3-LW-LS-106-0080 | 206.8d | 0d | Gravel & Gravel Mulch, Gravel N0.4 PEA [72 Sqm] | 6,148.11 | OK | 1.2.6.20 | PROC | PROC |
| PR-Z3-LW-LS-106-0100 |  | NMR 603 - Gravel (No. 4 PEA) |  | 6d | 2017-05-17 | 2017-05-24 | PR-Z3-LW-LS-106-0090 | 206.8d | 124.6d |  |  | OK | 1.2.6.20 | PROC | PROC |

Notes:
- PR-Z3-LW-LS-104-0090: Expenses: (New Expense Item) 77271
- PR-Z3-LW-LS-105-0090: Expenses: (New Expense Item) 420353
- PR-Z3-LW-LS-106-0090: Expenses: (New Expense Item) 6148.11

| ID | WBS | Activity | Type | Duration | Start | Finish | Predecessors | Total float | Free float | Resources | Cost | Wajid | RPI_P2 - BOQ ITEMS | RPI_P2 - PROCUREMENT | RPI_P2 - PHASE |
| --- | --- | --- | --- | --- | --- | --- | --- | --- | --- | --- | --- | --- | --- | --- | --- |
|  | 4 | **Sand** |  |  | 2016-09-18 | 2017-01-23 |  |  |  |  |  |  |  |  |  |
| PR-Z3-LW-LS-107-0010 |  | RFQ - Sand |  | 5.6d | 2016-09-18 | 2016-09-24 | PROC-GE-GE-GE-0010 FS+10d, PR-Z3-LW-LS-105-0010 SS | 310.2d | 0d |  |  | OK | 1.2.6.20 | PROC | PROC |
| PR-Z3-LW-LS-107-0020 |  | Material Submittal - Sand |  | 8d | 2016-09-24 | 2016-10-03 | PR-Z3-LW-LS-107-0010 | 310.2d | 0d |  |  | OK | 1.2.6.20 | PROC | PROC |
| PR-Z3-LW-LS-107-0030 |  | Material Approval - Sand |  | 11.2d | 2016-10-03 | 2016-10-16 | PR-Z3-LW-LS-107-0020 | 310.2d | 0d |  |  | OK | 1.2.6.20 | PROC | PROC |
| PR-Z3-LW-LS-107-0040 |  | Technical Evaluation - Sand |  | 8d | 2016-10-17 | 2016-10-25 | PR-Z3-LW-LS-107-0030 | 310.2d | 0d |  |  | OK | 1.2.6.20 | PROC | PROC |
| PR-Z3-LW-LS-107-0050 |  | PO - Sand |  | 11.2d | 2016-10-26 | 2016-11-08 | PR-Z3-LW-LS-107-0040 | 310.2d | 0d |  |  | OK | 1.2.6.20 | PROC | PROC |
| PR-Z3-LW-LS-107-0060 |  | NMR 601 - Sand |  | 4.8d | 2016-11-08 | 2016-11-13 | PR-Z3-LW-LS-107-0050 | 310.2d | 0d |  |  | OK | 1.2.6.20 | PROC | PROC |
| PR-Z3-LW-LS-107-0070 |  | NMR 602 - Sand |  | 4.8d | 2016-11-14 | 2016-11-19 | PR-Z3-LW-LS-107-0060 | 310.2d | 0d |  |  | OK | 1.2.6.20 | PROC | PROC |
| PR-Z3-LW-LS-107-0080 |  | Start of Material Delivery - Sand | milestone | 0d | 2016-11-19 | 2016-11-19 | PR-Z3-LW-LS-107-0070 | 310.2d | 0d |  |  | OK | 1.2.6.20 | PROC | PROC |
| PR-Z3-LW-LS-107-0090 |  | Complete Material Delivery - Sand |  | 48d | 2016-11-19 | 2017-01-14 | PR-Z3-LW-LS-107-0080 | 310.2d | 0d | Sand for Backfilling [9096.37 Cum] | 94,758.03 | OK | 1.2.6.20 | PROC | PROC |
| PR-Z3-LW-LS-107-0100 |  | NMR 603 - Sand |  | 8d | 2017-01-14 | 2017-01-23 | PR-Z3-LW-LS-107-0090 | 310.2d | 228d |  |  | OK | 1.2.6.20 | PROC | PROC |
|  | 5 | **Selected Fill (Backfilling)** |  |  | 2016-09-15 | 2017-03-01 |  |  |  |  |  |  |  |  |  |
| PR-Z3-LW-LS-108-100 |  | RFQ - Selected Fill (Backfilling) |  | 5.6d | 2016-09-15 | 2016-09-21 | PROC-GE-GE-GE-0010 FS+28d | 278.2d | 0d |  |  | OK | 1.2.6.20 | PROC | PROC |
| PR-Z3-LW-LS-108-110 |  | Material Submittal - Selected Fill (Backfilling) |  | 8d | 2016-09-21 | 2016-10-01 | PR-Z3-LW-LS-108-100 | 278.2d | 0d |  |  | OK | 1.2.6.20 | PROC | PROC |
| PR-Z3-LW-LS-108-120 |  | Material Approval - Selected Fill (Backfilling) |  | 11.2d | 2016-10-01 | 2016-10-13 | PR-Z3-LW-LS-108-110 | 278.2d | 0d |  |  | OK | 1.2.6.20 | PROC | PROC |
| PR-Z3-LW-LS-108-130 |  | Technical Evaluation - Selected Fill (Backfilling) |  | 8d | 2016-10-15 | 2016-10-23 | PR-Z3-LW-LS-108-120 | 278.2d | 0d |  |  | OK | 1.2.6.20 | PROC | PROC |
| PR-Z3-LW-LS-108-140 |  | PO - Selected Fill (Backfilling) |  | 11.2d | 2016-10-24 | 2016-11-06 | PR-Z3-LW-LS-108-130 | 278.2d | 0d |  |  | OK | 1.2.6.20 | PROC | PROC |
| PR-Z3-LW-LS-108-150 |  | NMR 601 - Selected Fill (Backfilling) |  | 4.8d | 2016-11-06 | 2016-11-10 | PR-Z3-LW-LS-108-140 | 278.2d | 0d |  |  | OK | 1.2.6.20 | PROC | PROC |
| PR-Z3-LW-LS-108-160 |  | NMR 602 - Selected Fill (Backfilling) |  | 4.8d | 2016-11-12 | 2016-11-16 | PR-Z3-LW-LS-108-150 | 278.2d | 0d |  |  | OK | 1.2.6.20 | PROC | PROC |
| PR-Z3-LW-LS-108-170 |  | Start of Material Delivery - Selected Fill (Backfilling) | milestone | 0d | 2016-11-16 | 2016-11-16 | PR-Z3-LW-LS-108-160 | 278.2d | 0d |  |  | OK | 1.2.6.20 | PROC | PROC |
| PR-Z3-LW-LS-108-180 |  | Complete Material Delivery - Selected Fill (Backfilling) |  | 90d | 2016-11-16 | 2017-03-01 | PR-Z3-LW-LS-108-170 | 278.2d | 196d | Selected Fill (Backfilling) [3608 Cum] | 138,658.25 | OK | 1.2.6.20 | PROC | PROC |
|  | 6 | **Precast Concrete Pavers, Curb (Concrete Edger), Interlocking Paver, Curb Gutter** |  |  | 2016-09-18 | 2017-05-07 |  |  |  |  |  |  |  |  |  |
| PR-Z3-LW-LS-109-0010 |  | RFQ - Precast Concrete Pavers, Interlocking Paver |  | 5.6d | 2016-09-18 | 2016-09-24 | PROC-GE-GE-GE-0010 FS+30d | 221d | 0d |  |  | OK | 1.2.6.20 | PROC | PROC |
| PR-Z3-LW-LS-109-0020 |  | Material Submittal - Precast Concrete Pavers, Interlocking Paver |  | 8d | 2016-09-24 | 2016-10-03 | PR-Z3-LW-LS-109-0010 | 221d | 0d |  |  | OK | 1.2.6.20 | PROC | PROC |
| PR-Z3-LW-LS-109-0030 |  | Material Approval - Precast Concrete Pavers, Interlocking Paver |  | 11.2d | 2016-10-03 | 2016-10-16 | PR-Z3-LW-LS-109-0020 | 221d | 0d |  |  | OK | 1.2.6.20 | PROC | PROC |
| PR-Z3-LW-LS-109-0040 |  | Technical Evaluation - Precast Concrete Pavers, Interlocking Paver |  | 8d | 2016-10-17 | 2016-10-25 | PR-Z3-LW-LS-109-0030 | 221d | 0d |  |  | OK | 1.2.6.20 | PROC | PROC |
| PR-Z3-LW-LS-109-0050 |  | PO - Precast Concrete Pavers, Interlocking Paver |  | 11.2d | 2016-10-26 | 2016-11-08 | PR-Z3-LW-LS-109-0040 | 221d | 0d |  |  | OK | 1.2.6.20 | PROC | PROC |
| PR-Z3-LW-LS-109-0060 |  | NMR 601 - Precast Concrete Pavers, Interlocking Paver |  | 4.8d | 2016-11-08 | 2016-11-13 | PR-Z3-LW-LS-109-0050 | 221d | 0d |  |  | OK | 1.2.6.20 | PROC | PROC |
| PR-Z3-LW-LS-109-0070 |  | NMR 602 - Precast Concrete Pavers, Interlocking Paver |  | 4.8d | 2016-11-14 | 2016-11-19 | PR-Z3-LW-LS-109-0060 | 221d | 0d |  |  | OK | 1.2.6.20 | PROC | PROC |
| PR-Z3-LW-LS-109-0080 |  | Start of Material Delivery - Precast Concrete Pavers, Interlocking Paver | milestone | 0d | 2016-12-07 | 2016-12-07 | PR-Z3-LW-LS-109-0070 FS+15.2d | 221d | 0d |  |  | OK | 1.2.6.20 | PROC | PROC |
| PR-Z3-LW-LS-109-0090 |  | Complete Material Delivery - Precast Concrete Pavers, Interlocking Paver |  | 130d | 2016-12-07 | 2017-05-07 | PR-Z3-LW-LS-109-0080 | 221d | 138.8d | Precast Concrete Pavers, Interlocking Paver [2224.35 Sqm] | 609,893.44 | OK | 1.2.6.20 | PROC | PROC |

Notes:
- PR-Z3-LW-LS-107-0090: Expenses: (New Expense Item) 94758
- PR-Z3-LW-LS-108-180: Expenses: (New Expense Item) 138658
- PR-Z3-LW-LS-109-0090: Expenses: (New Expense Item) 609893

| ID | WBS | Activity | Type | Duration | Start | Finish | Predecessors | Total float | Free float | Resources | Cost | Wajid | RPI_P2 - BOQ ITEMS | RPI_P2 - PROCUREMENT | RPI_P2 - PHASE |
| --- | --- | --- | --- | --- | --- | --- | --- | --- | --- | --- | --- | --- | --- | --- | --- |
|  | 7 | **Curb (Concrete Edger), Curb Gutter** |  |  | 2016-09-18 | 2017-05-07 |  |  |  |  |  |  |  |  |  |
| PR-Z3-LW-LS-109-100 |  | RFQ - Curb (Concrete Edger), Curb Gutter |  | 4d | 2016-09-18 | 2016-09-22 | PROC-GE-GE-GE-0010 FS+30d | 221.8d | 0d |  |  | OK | 1.2.6.20 | PROC | PROC |
| PR-Z3-LW-LS-109-110 |  | Material Submittal - Curb (Concrete Edger), Curb Gutter |  | 4d | 2016-09-22 | 2016-09-27 | PR-Z3-LW-LS-109-100 | 221.8d | 0d |  |  | OK | 1.2.6.20 | PROC | PROC |
| PR-Z3-LW-LS-109-120 |  | Material Approval - Curb (Concrete Edger), Curb Gutter |  | 4d | 2016-09-27 | 2016-10-02 | PR-Z3-LW-LS-109-110 | 221.8d | 0d |  |  | OK | 1.2.6.20 | PROC | PROC |
| PR-Z3-LW-LS-109-130 |  | Technical Evaluation - Curb (Concrete Edger), Curb Gutter |  | 4d | 2016-10-02 | 2016-10-06 | PR-Z3-LW-LS-109-120 | 221.8d | 0d |  |  | OK | 1.2.6.20 | PROC | PROC |
| PR-Z3-LW-LS-109-140 |  | PO - Curb (Concrete Edger), Curb Gutter |  | 4d | 2016-10-06 | 2016-10-11 | PR-Z3-LW-LS-109-130 | 221.8d | 0d |  |  | OK | 1.2.6.20 | PROC | PROC |
| PR-Z3-LW-LS-109-150 |  | NMR 601 - Curb (Concrete Edger), Curb Gutter |  | 4d | 2016-10-11 | 2016-10-16 | PR-Z3-LW-LS-109-140 | 221.8d | 0d |  |  | OK | 1.2.6.20 | PROC | PROC |
| PR-Z3-LW-LS-109-160 |  | NMR 602 - Curb (Concrete Edger), Curb Gutter |  | 4d | 2016-10-16 | 2016-10-20 | PR-Z3-LW-LS-109-150 | 221.8d | 0d |  |  | OK | 1.2.6.20 | PROC | PROC |
| PR-Z3-LW-LS-109-170 |  | Start of Material Delivery - Curb (Concrete Edger), Curb Gutter | milestone | 0d | 2016-12-06 | 2016-12-06 | PR-Z3-LW-LS-109-160 FS+40d | 221.8d | 0d |  |  | OK | 1.2.6.20 | PROC | PROC |
| PR-Z3-LW-LS-109-180 |  | Complete Material Delivery - Curb (Concrete Edger), Curb Gutter |  | 130d | 2016-12-06 | 2017-05-07 | PR-Z3-LW-LS-109-170 | 221.8d | 139.6d | Curb (Concrete Edger), Curb & Gutter [11887 Lm] | 911,905.22 | OK | 1.2.6.20 | PROC | PROC |
|  | 8 | **Ready Mix Concrete** |  |  | 2016-08-23 | 2017-06-21 |  |  |  |  |  |  |  |  |  |
| PR-Z3-LW-LS-111-0010 |  | RFQ - Ready Mix Concrete |  | 9.6d | 2016-08-23 | 2016-09-03 | PROC-GE-GE-GE-0010 FS+12d | 182.2d | 0d |  |  | OK | 1.2.6.20 | PROC | PROC |
| PR-Z3-LW-LS-111-0020 |  | Material Submittal - Ready Mix Concrete |  | 8d | 2016-09-03 | 2016-09-17 | PR-Z3-LW-LS-111-0010 | 182.2d | 0d |  |  | OK | 1.2.6.20 | PROC | PROC |
| PR-Z3-LW-LS-111-0030 |  | Material Approval - Ready Mix Concrete |  | 11.2d | 2016-09-17 | 2016-09-29 | PR-Z3-LW-LS-111-0020 | 182.2d | 0d |  |  | OK | 1.2.6.20 | PROC | PROC |
| PR-Z3-LW-LS-111-0040 |  | Technical Evaluation - Ready Mix Concrete |  | 8d | 2016-10-01 | 2016-10-09 | PR-Z3-LW-LS-111-0030 | 182.2d | 0d |  |  | OK | 1.2.6.20 | PROC | PROC |
| PR-Z3-LW-LS-111-0050 |  | PO - Ready Mix Concrete |  | 11.2d | 2016-10-10 | 2016-10-23 | PR-Z3-LW-LS-111-0040 | 182.2d | 0d |  |  | OK | 1.2.6.20 | PROC | PROC |
| PR-Z3-LW-LS-111-0060 |  | NMR 601 - Ready Mix Concrete |  | 4.8d | 2016-10-23 | 2016-10-27 | PR-Z3-LW-LS-111-0050 | 182.2d | 0d |  |  | OK | 1.2.6.20 | PROC | PROC |
| PR-Z3-LW-LS-111-0070 |  | NMR 602 - Ready Mix Concrete |  | 4.8d | 2016-10-29 | 2016-11-02 | PR-Z3-LW-LS-111-0060 | 182.2d | 0d |  |  | OK | 1.2.6.20 | PROC | PROC |
| PR-Z3-LW-LS-111-0080 |  | Start of Material Delivery - Ready Mix Concrete | milestone | 0d | 2016-12-07 | 2016-12-07 | PR-Z3-LW-LS-111-0070 FS+30d | 182.2d | 0d |  |  | OK | 1.2.6.20 | PROC | PROC |
| PR-Z3-LW-LS-111-0090 |  | Complete Material Delivery - Ready Mix Concrete |  | 160d | 2016-12-07 | 2017-06-12 | PR-Z3-LW-LS-111-0080 | 182.2d | 0d | Ready Mix Concrete [18913.9 Cum] | 2,586,921.31 | OK | 1.2.6.20 | PROC | PROC |
| PR-Z3-LW-LS-111-0100 |  | NMR 603 - Ready Mix Concrete |  | 8d | 2017-06-12 | 2017-06-21 | PR-Z3-LW-LS-111-0090 | 182.2d | 100d |  |  | OK | 1.2.6.20 | PROC | PROC |
|  | 9 | **Rubber Tiles (Rubber Tile Surface)** |  |  | 2016-10-05 | 2017-06-08 |  |  |  |  |  |  |  |  |  |
| PR-Z3-LW-LS-112-0010 |  | RFQ - Rubber Tiles (Rubber Tile Surface) |  | 5.6d | 2016-10-05 | 2016-10-11 | PROC-GE-GE-GE-0010 FS+45d | 176.8d | 0d |  |  | OK | 1.2.6.20 | PROC | PROC |
| PR-Z3-LW-LS-112-0020 |  | Material Submittal - Rubber Tiles (Rubber Tile Surface) |  | 8d | 2016-10-11 | 2016-10-20 | PR-Z3-LW-LS-112-0010 | 176.8d | 0d |  |  | OK | 1.2.6.20 | PROC | PROC |
| PR-Z3-LW-LS-112-0030 |  | Material Approval - Rubber Tiles (Rubber Tile Surface) |  | 11.2d | 2016-10-20 | 2016-11-02 | PR-Z3-LW-LS-112-0020 | 176.8d | 0d |  |  | OK | 1.2.6.20 | PROC | PROC |
| PR-Z3-LW-LS-112-0040 |  | Technical Evaluation - Rubber Tiles (Rubber Tile Surface) |  | 8d | 2016-11-03 | 2016-11-12 | PR-Z3-LW-LS-112-0030 | 176.8d | 0d |  |  | OK | 1.2.6.20 | PROC | PROC |
| PR-Z3-LW-LS-112-0050 |  | PO - Rubber Tiles (Rubber Tile Surface) |  | 11.2d | 2016-11-13 | 2016-11-26 | PR-Z3-LW-LS-112-0040 | 176.8d | 0d |  |  | OK | 1.2.6.20 | PROC | PROC |
| PR-Z3-LW-LS-112-0060 |  | NMR 601 - Rubber Tiles (Rubber Tile Surface) |  | 4.8d | 2016-11-26 | 2016-11-30 | PR-Z3-LW-LS-112-0050 | 176.8d | 0d |  |  | OK | 1.2.6.20 | PROC | PROC |
| PR-Z3-LW-LS-112-0070 |  | NMR 602 - Rubber Tiles (Rubber Tile Surface) |  | 4.8d | 2016-12-01 | 2016-12-06 | PR-Z3-LW-LS-112-0060 | 176.8d | 0d |  |  | OK | 1.2.6.20 | PROC | PROC |
| PR-Z3-LW-LS-112-0080 |  | Start of Material Delivery - Rubber Tiles (Rubber Tile Surface) | milestone | 0d | 2017-04-25 | 2017-04-25 | PR-Z3-LW-LS-112-0070 FS+120d | 176.8d | 0d |  |  | OK | 1.2.6.20 | PROC | PROC |
| PR-Z3-LW-LS-112-0090 |  | Complete Material Delivery - Rubber Tiles (Rubber Tile Surface) |  | 30d | 2017-04-25 | 2017-05-30 | PR-Z3-LW-LS-112-0080 | 193.2d | 0d | Rubber Tiles (Rubber Tile Surface) [365 Sqm] | 168,824.02 | OK | 1.2.6.20 | PROC | PROC |
| PR-Z3-LW-LS-112-0100 |  | NMR 603 - Rubber Tiles (Rubber Tile Surface) |  | 8d | 2017-05-30 | 2017-06-08 | PR-Z3-LW-LS-112-0090 | 193.2d | 111d |  |  | OK | 1.2.6.20 | PROC | PROC |

Notes:
- PR-Z3-LW-LS-109-180: Expenses: (New Expense Item) 911905
- PR-Z3-LW-LS-111-0090: Expenses: (New Expense Item) 2586921
- PR-Z3-LW-LS-112-0090: Expenses: (New Expense Item) 168824

| ID | WBS | Activity | Type | Duration | Start | Finish | Predecessors | Total float | Free float | Resources | Cost | Wajid | RPI_P2 - BOQ ITEMS | RPI_P2 - PROCUREMENT | RPI_P2 - PHASE |
| --- | --- | --- | --- | --- | --- | --- | --- | --- | --- | --- | --- | --- | --- | --- | --- |
|  | 10 | **Protective Railing** |  |  | 2016-10-23 | 2017-07-29 |  |  |  |  |  |  |  |  |  |
| PR-Z3-LW-LS-113-0010 |  | RFQ - Protective Railing |  | 5.6d | 2016-10-23 | 2016-10-29 | PROC-GE-GE-GE-0010 FS+60d | 154.8d | 0d |  |  | OK | 1.2.6.20 | PROC | PROC |
| PR-Z3-LW-LS-113-0020 |  | Material Submittal - Protective Railing |  | 8d | 2016-10-29 | 2016-11-07 | PR-Z3-LW-LS-113-0010 | 154.8d | 0d |  |  | OK | 1.2.6.20 | PROC | PROC |
| PR-Z3-LW-LS-113-0030 |  | Material Approval - Protective Railing |  | 11.2d | 2016-11-07 | 2016-11-20 | PR-Z3-LW-LS-113-0020 | 154.8d | 0d |  |  | OK | 1.2.6.20 | PROC | PROC |
| PR-Z3-LW-LS-113-0040 |  | Technical Evaluation - Protective Railing |  | 8d | 2016-11-21 | 2016-11-29 | PR-Z3-LW-LS-113-0030 | 154.8d | 0d |  |  | OK | 1.2.6.20 | PROC | PROC |
| PR-Z3-LW-LS-113-0050 |  | PO - Protective Railing |  | 11.2d | 2016-11-30 | 2016-12-13 | PR-Z3-LW-LS-113-0040 | 154.8d | 0d |  |  | OK | 1.2.6.20 | PROC | PROC |
| PR-Z3-LW-LS-113-0060 |  | NMR 601 - Protective Railing |  | 12d | 2016-12-13 | 2016-12-27 | PR-Z3-LW-LS-113-0050 | 154.8d | 0d |  |  | OK | 1.2.6.20 | PROC | PROC |
| PR-Z3-LW-LS-113-0070 |  | NMR 602 - Protective Railing |  | 12d | 2016-12-27 | 2017-01-10 | PR-Z3-LW-LS-113-0060 | 154.8d | 0d |  |  | OK | 1.2.6.20 | PROC | PROC |
| PR-Z3-LW-LS-113-0080 |  | Start of Material Delivery - Protective Railing | milestone | 0d | 2017-05-06 | 2017-05-06 | PR-Z3-LW-LS-113-0070 FS+99d | 154.8d | 0d |  |  | OK | 1.2.6.20 | PROC | PROC |
| PR-Z3-LW-LS-113-0090 |  | Complete Material Delivery - Protective Railing |  | 60d | 2017-05-06 | 2017-07-19 | PR-Z3-LW-LS-113-0080 | 154.8d | 0d | Protective Railing [2930 Lm] | 9,779,387 | OK | 1.2.6.20 | PROC | PROC |
| PR-Z3-LW-LS-113-0100 |  | NMR 603 - Protective Railing |  | 8d | 2017-07-19 | 2017-07-29 | PR-Z3-LW-LS-113-0090 | 154.8d | 72.6d |  |  | OK | 1.2.6.20 | PROC | PROC |
|  | 11 | **Steel Bicycle Rack Assembly** |  |  | 2016-10-05 | 2017-06-08 |  |  |  |  |  |  |  |  |  |
| PR-Z3-LW-LS-114-0010 |  | RFQ - Steel Bicycle Rack Assembly |  | 5.6d | 2016-10-05 | 2016-10-11 | PROC-GE-GE-GE-0010 FS+45d | 193.8d | 0d |  |  | OK | 1.2.6.20 | PROC | PROC |
| PR-Z3-LW-LS-114-0020 |  | Material Submittal - Steel Bicycle Rack Assembly |  | 8d | 2016-10-11 | 2016-10-20 | PR-Z3-LW-LS-114-0010 | 193.8d | 0d |  |  | OK | 1.2.6.20 | PROC | PROC |
| PR-Z3-LW-LS-114-0030 |  | Material Approval - Steel Bicycle Rack Assembly |  | 11.2d | 2016-10-20 | 2016-11-02 | PR-Z3-LW-LS-114-0020 | 193.8d | 0d |  |  | OK | 1.2.6.20 | PROC | PROC |
| PR-Z3-LW-LS-114-0040 |  | Technical Evaluation - Steel Bicycle Rack Assembly |  | 8d | 2016-11-03 | 2016-11-12 | PR-Z3-LW-LS-114-0030 | 193.8d | 0d |  |  | OK | 1.2.6.20 | PROC | PROC |
| PR-Z3-LW-LS-114-0050 |  | PO - Steel Bicycle Rack Assembly |  | 11.2d | 2016-11-13 | 2016-11-26 | PR-Z3-LW-LS-114-0040 | 193.8d | 0d |  |  | OK | 1.2.6.20 | PROC | PROC |
| PR-Z3-LW-LS-114-0060 |  | NMR 601 - Steel Bicycle Rack Assembly |  | 12d | 2016-11-26 | 2016-12-10 | PR-Z3-LW-LS-114-0050 | 193.8d | 0d |  |  | OK | 1.2.6.20 | PROC | PROC |
| PR-Z3-LW-LS-114-0070 |  | NMR 602 - Steel Bicycle Rack Assembly |  | 12d | 2016-12-10 | 2016-12-24 | PR-Z3-LW-LS-114-0060 | 193.8d | 0d |  |  | OK | 1.2.6.20 | PROC | PROC |
| PR-Z3-LW-LS-114-0080 |  | Start of Material Delivery - Steel Bicycle Rack Assembly | milestone | 0d | 2017-05-13 | 2017-05-13 | PR-Z3-LW-LS-114-0070 FS+120d | 193.8d | 0d |  |  | OK | 1.2.6.20 | PROC | PROC |
| PR-Z3-LW-LS-114-0090 |  | Complete Material Delivery - Steel Bicycle Rack Assembly |  | 15d | 2017-05-13 | 2017-05-30 | PR-Z3-LW-LS-114-0080 | 193.8d | 0d | Steel Bicycle Rack Assembly [126 Lm] | 170,353.93 | OK | 1.2.6.20 | PROC | PROC |
| PR-Z3-LW-LS-114-0100 |  | NMR 603 - Steel Bicycle Rack Assembly |  | 8d | 2017-05-30 | 2017-06-08 | PR-Z3-LW-LS-114-0090 | 193.8d | 111.6d |  |  | OK | 1.2.6.20 | PROC | PROC |
|  | 12 | **Paint for Marking** |  |  | 2016-10-05 | 2017-06-08 |  |  |  |  |  |  |  |  |  |
| PR-Z3-LW-LS-114-0110 |  | RFQ - Paint for Marking |  | 5.6d | 2016-10-05 | 2016-10-11 | PR-Z3-LW-LS-114-0010 SS | 193.8d | 0d |  |  | OK | 1.2.6.20 | PROC | PROC |
| PR-Z3-LW-LS-114-0120 |  | Material Submittal - Paint for Marking |  | 8d | 2016-10-11 | 2016-10-20 | PR-Z3-LW-LS-114-0110 | 193.8d | 0d |  |  | OK | 1.2.6.20 | PROC | PROC |
| PR-Z3-LW-LS-114-0130 |  | Material Approval - Paint for Marking |  | 11.2d | 2016-10-20 | 2016-11-02 | PR-Z3-LW-LS-114-0120 | 193.8d | 0d |  |  | OK | 1.2.6.20 | PROC | PROC |
| PR-Z3-LW-LS-114-0140 |  | Technical Evaluation - Paint for Marking |  | 8d | 2016-11-03 | 2016-11-12 | PR-Z3-LW-LS-114-0130 | 193.8d | 0d |  |  | OK | 1.2.6.20 | PROC | PROC |
| PR-Z3-LW-LS-114-0150 |  | PO - Paint for Marking |  | 11.2d | 2016-11-13 | 2016-11-26 | PR-Z3-LW-LS-114-0140 | 193.8d | 0d |  |  | OK | 1.2.6.20 | PROC | PROC |
| PR-Z3-LW-LS-114-0160 |  | NMR 601 - Paint for Marking |  | 12d | 2016-11-26 | 2016-12-10 | PR-Z3-LW-LS-114-0150 | 193.8d | 0d |  |  | OK | 1.2.6.20 | PROC | PROC |
| PR-Z3-LW-LS-114-0170 |  | NMR 602 - Paint for Marking |  | 12d | 2016-12-10 | 2016-12-24 | PR-Z3-LW-LS-114-0160 | 193.8d | 0d |  |  | OK | 1.2.6.20 | PROC | PROC |
| PR-Z3-LW-LS-114-0180 |  | Start of Material Delivery - Paint for Marking | milestone | 0d | 2017-05-13 | 2017-05-13 | PR-Z3-LW-LS-114-0170 FS+120d | 193.8d | 0d |  |  | OK | 1.2.6.20 | PROC | PROC |
| PR-Z3-LW-LS-114-0190 |  | Complete Material Delivery - Paint for Marking |  | 15d | 2017-05-13 | 2017-05-30 | PR-Z3-LW-LS-114-0180 | 193.8d | 0d | Paint for Marking & Road Marking [324 Sqm] | 11,527.71 | OK | 1.2.6.20 | PROC | PROC |
| PR-Z3-LW-LS-114-0200 |  | NMR 603 - Paint for Marking |  | 8d | 2017-05-30 | 2017-06-08 | PR-Z3-LW-LS-114-0190 | 193.8d | 111.6d |  |  | OK | 1.2.6.20 | PROC | PROC |

Notes:
- PR-Z3-LW-LS-113-0090: Expenses: (New Expense Item) 9779387
- PR-Z3-LW-LS-114-0090: Expenses: (New Expense Item) 170354
- PR-Z3-LW-LS-114-0190: Expenses: (New Expense Item) 11527.7

| ID | WBS | Activity | Type | Duration | Start | Finish | Predecessors | Total float | Free float | Resources | Cost | Wajid | RPI_P2 - BOQ ITEMS | RPI_P2 - PROCUREMENT | RPI_P2 - PHASE |
| --- | --- | --- | --- | --- | --- | --- | --- | --- | --- | --- | --- | --- | --- | --- | --- |
|  | 13 | **Stainless Steel Hand Rails** |  |  | 2016-10-05 | 2017-04-17 |  |  |  |  |  |  |  |  |  |
| PR-Z3-LW-LS-115-0010 |  | RFQ - Stainless Steel Hand Rails |  | 5.6d | 2016-10-05 | 2016-10-11 | PROC-GE-GE-GE-0010 FS+45d | 234.4d | 0d |  |  | OK | 1.2.6.20 | PROC | PROC |
| PR-Z3-LW-LS-115-0020 |  | Material Submittal - Stainless Steel Hand Rails |  | 8d | 2016-10-11 | 2016-10-20 | PR-Z3-LW-LS-115-0010 | 234.4d | 0d |  |  | OK | 1.2.6.20 | PROC | PROC |
| PR-Z3-LW-LS-115-0030 |  | Material Approval - Stainless Steel Hand Rails |  | 11.2d | 2016-10-20 | 2016-11-02 | PR-Z3-LW-LS-115-0020 | 234.4d | 0d |  |  | OK | 1.2.6.20 | PROC | PROC |
| PR-Z3-LW-LS-115-0040 |  | Technical Evaluation - Stainless Steel Hand Rails |  | 8d | 2016-11-03 | 2016-11-12 | PR-Z3-LW-LS-115-0030 | 234.4d | 0d |  |  | OK | 1.2.6.20 | PROC | PROC |
| PR-Z3-LW-LS-115-0050 |  | PO - Stainless Steel Hand Rails |  | 11.2d | 2016-11-13 | 2016-11-26 | PR-Z3-LW-LS-115-0040 | 234.4d | 0d |  |  | OK | 1.2.6.20 | PROC | PROC |
| PR-Z3-LW-LS-115-0060 |  | NMR 601 - Stainless Steel Hand Rails |  | 12d | 2016-11-26 | 2016-12-10 | PR-Z3-LW-LS-115-0050 | 234.4d | 0d |  |  | OK | 1.2.6.20 | PROC | PROC |
| PR-Z3-LW-LS-115-0070 |  | NMR 602 - Stainless Steel Hand Rails |  | 12d | 2016-12-10 | 2016-12-24 | PR-Z3-LW-LS-115-0060 | 234.4d | 0d |  |  | OK | 1.2.6.20 | PROC | PROC |
| PR-Z3-LW-LS-115-0080 |  | Start of Material Delivery - Stainless Steel Hand Rails | milestone | 0d | 2017-03-04 | 2017-03-04 | PR-Z3-LW-LS-115-0070 FS+60d | 234.4d | 0d |  |  | OK | 1.2.6.20 | PROC | PROC |
| PR-Z3-LW-LS-115-0090 |  | Complete Material Delivery - Stainless Steel Hand Rails |  | 30d | 2017-03-04 | 2017-04-08 | PR-Z3-LW-LS-115-0080 | 238.8d | 0d | Stainless Steel Hand Rails [94 Lm] | 280,934.55 | OK | 1.2.6.20 | PROC | PROC |
| PR-Z3-LW-LS-115-0100 |  | NMR 603 - Stainless Steel Hand Rails |  | 8d | 2017-04-08 | 2017-04-17 | PR-Z3-LW-LS-115-0090 | 238.8d | 156.6d |  |  | OK | 1.2.6.20 | PROC | PROC |
|  | 14 | **Bermuda Turf Sod / Grass** |  |  | 2016-10-23 | 2017-07-24 |  |  |  |  |  |  |  |  |  |
| PR-Z3-LW-LS-116-0010 |  | RFQ - Bermuda Turf Sod / Grass |  | 5.6d | 2016-10-23 | 2016-10-29 | PROC-GE-GE-GE-0010 FS+60d | 158.2d | 0d |  |  | OK | 1.2.6.20 | PROC | PROC |
| PR-Z3-LW-LS-116-0020 |  | Material Submittal - Bermuda Turf Sod / Grass |  | 8d | 2016-10-29 | 2016-11-07 | PR-Z3-LW-LS-116-0010 | 158.2d | 0d |  |  | OK | 1.2.6.20 | PROC | PROC |
| PR-Z3-LW-LS-116-0030 |  | Material Approval - Bermuda Turf Sod / Grass |  | 11.2d | 2016-11-07 | 2016-11-20 | PR-Z3-LW-LS-116-0020 | 158.2d | 0d |  |  | OK | 1.2.6.20 | PROC | PROC |
| PR-Z3-LW-LS-116-0040 |  | Technical Evaluation - Bermuda Turf Sod / Grass |  | 8d | 2016-11-21 | 2016-11-29 | PR-Z3-LW-LS-116-0030 | 158.2d | 0d |  |  | OK | 1.2.6.20 | PROC | PROC |
| PR-Z3-LW-LS-116-0050 |  | PO - Bermuda Turf Sod / Grass |  | 11.2d | 2016-11-30 | 2016-12-13 | PR-Z3-LW-LS-116-0040 | 158.2d | 0d |  |  | OK | 1.2.6.20 | PROC | PROC |
| PR-Z3-LW-LS-116-0060 |  | NMR 601 - Bermuda Turf Sod / Grass |  | 4.8d | 2016-12-13 | 2016-12-18 | PR-Z3-LW-LS-116-0050 | 158.2d | 0d |  |  | OK | 1.2.6.20 | PROC | PROC |
| PR-Z3-LW-LS-116-0070 |  | NMR 602 - Bermuda Turf Sod / Grass |  | 4.8d | 2016-12-19 | 2016-12-24 | PR-Z3-LW-LS-116-0060 | 158.2d | 0d |  |  | OK | 1.2.6.20 | PROC | PROC |
| PR-Z3-LW-LS-116-0080 |  | Start of Material Delivery - Bermuda Turf Sod / Grass | milestone | 0d | 2017-06-17 | 2017-06-17 | PR-Z3-LW-LS-116-0070 FS+150d | 158.2d | 0d |  |  | OK | 1.2.6.20 | PROC | PROC |
| PR-Z3-LW-LS-116-0090 |  | Complete Material Delivery - Bermuda Turf Sod / Grass |  | 20d | 2017-06-17 | 2017-07-15 | PR-Z3-LW-LS-116-0080 | 158.2d | 0d | Bermuda Turf Sod / Grass [400 Sqm] | 90,143.84 | OK | 1.2.6.20 | PROC | PROC |
| PR-Z3-LW-LS-116-0100 |  | NMR 603 - Bermuda Turf Sod / Grass |  | 8d | 2017-07-15 | 2017-07-24 | PR-Z3-LW-LS-116-0090 | 158.2d | 76d |  |  | OK | 1.2.6.20 | PROC | PROC |
|  | 15 | **Galvanized Pipe Railing covered with Rubber Guard 50mm Dia HD** |  |  | 2016-10-23 | 2017-06-20 |  |  |  |  |  |  |  |  |  |
| PR-Z3-LW-LS-117-0010 |  | RFQ - Galvanized Pipe Railing covered with Rubber Guard 50mm Dia HD |  | 5.6d | 2016-10-23 | 2016-10-29 | PR-Z3-LW-LS-113-0010 SS, PROC-GE-GE-GE-0010 FS+30d | 179.4d | 0d |  |  | OK | 1.2.6.20 | PROC | PROC |
| PR-Z3-LW-LS-117-0020 |  | Material Submittal - Galvanized Pipe Railing covered with Rubber Guard 50mm Dia HD |  | 8d | 2016-10-29 | 2016-11-07 | PR-Z3-LW-LS-117-0010 | 179.4d | 0d |  |  | OK | 1.2.6.20 | PROC | PROC |
| PR-Z3-LW-LS-117-0030 |  | Material Approval - Galvanized Pipe Railing covered with Rubber Guard 50mm Dia HD |  | 11.2d | 2016-11-07 | 2016-11-20 | PR-Z3-LW-LS-117-0020 | 179.4d | 0d |  |  | OK | 1.2.6.20 | PROC | PROC |
| PR-Z3-LW-LS-117-0040 |  | Technical Evaluation - Galvanized Pipe Railing covered with Rubber Guard 50mm Dia HD |  | 8d | 2016-11-21 | 2016-11-29 | PR-Z3-LW-LS-117-0030 | 179.4d | 0d |  |  | OK | 1.2.6.20 | PROC | PROC |
| PR-Z3-LW-LS-117-0050 |  | PO - Galvanized Pipe Railing covered with Rubber Guard 50mm Dia HD |  | 11.2d | 2016-11-30 | 2016-12-13 | PR-Z3-LW-LS-117-0040 | 179.4d | 0d |  |  | OK | 1.2.6.20 | PROC | PROC |
| PR-Z3-LW-LS-117-0060 |  | NMR 601 - Galvanized Pipe Railing covered with Rubber Guard 50mm Dia HD |  | 12d | 2016-12-13 | 2016-12-27 | PR-Z3-LW-LS-117-0050 | 179.4d | 0d |  |  | OK | 1.2.6.20 | PROC | PROC |
| PR-Z3-LW-LS-117-0070 |  | NMR 602 - Galvanized Pipe Railing covered with Rubber Guard 50mm Dia HD |  | 12d | 2016-12-27 | 2017-01-10 | PR-Z3-LW-LS-117-0060 | 179.4d | 0d |  |  | OK | 1.2.6.20 | PROC | PROC |
| PR-Z3-LW-LS-117-0080 |  | Start of Material Delivery - Galvanized Pipe Railing covered with Rubber Guard 50mm Dia HD | milestone | 0d | 2017-05-07 | 2017-05-07 | PR-Z3-LW-LS-117-0070 FS+100d | 179.4d | 0d |  |  | OK | 1.2.6.20 | PROC | PROC |
| PR-Z3-LW-LS-117-0090 |  | Complete Material Delivery - Galvanized Pipe Railing covered with Rubber Guard 50mm Dia HD |  | 30d | 2017-05-07 | 2017-06-11 | PR-Z3-LW-LS-117-0080 | 183.8d | 0d | Galvanized Pipe Railing covered with Rubber Guards 50 mm dia HD [90 Lm] | 140,894.23 | OK | 1.2.6.20 | PROC | PROC |
| PR-Z3-LW-LS-117-0100 |  | NMR 603 - Galvanized Pipe Railing covered with Rubber Guard 50mm Dia HD |  | 8d | 2017-06-11 | 2017-06-20 | PR-Z3-LW-LS-117-0090 | 183.8d | 101.6d |  |  | OK | 1.2.6.20 | PROC | PROC |

Notes:
- PR-Z3-LW-LS-115-0090: Expenses: (New Expense Item) 280935
- PR-Z3-LW-LS-116-0090: Expenses: (New Expense Item) 90143.8
- PR-Z3-LW-LS-117-0090: Expenses: (New Expense Item) 140894

| ID | WBS | Activity | Type | Duration | Start | Finish | Predecessors | Total float | Free float | Resources | Cost | Wajid | RPI_P2 - BOQ ITEMS | RPI_P2 - PROCUREMENT | RPI_P2 - PHASE |
| --- | --- | --- | --- | --- | --- | --- | --- | --- | --- | --- | --- | --- | --- | --- | --- |
|  | 16 | **Precast Rounded Crested Concrete Weir** |  |  | 2016-10-23 | 2017-05-25 |  |  |  |  |  |  |  |  |  |
| PR-Z3-LW-LS-118-0010 |  | RFQ - Precast Round Crested Concrete Weir |  | 5.6d | 2016-10-23 | 2016-10-29 | PROC-GE-GE-GE-0010 FS+60d | 205.8d | 0d |  |  | OK | 1.2.6.20 | PROC | PROC |
| PR-Z3-LW-LS-118-0020 |  | Material Submittal - Precast Round Crested Concrete Weir |  | 8d | 2016-10-29 | 2016-11-07 | PR-Z3-LW-LS-118-0010 | 205.8d | 0d |  |  | OK | 1.2.6.20 | PROC | PROC |
| PR-Z3-LW-LS-118-0030 |  | Material Approval - Precast Round Crested Concrete Weir |  | 11.2d | 2016-11-07 | 2016-11-20 | PR-Z3-LW-LS-118-0020 | 205.8d | 0d |  |  | OK | 1.2.6.20 | PROC | PROC |
| PR-Z3-LW-LS-118-0040 |  | Technical Evaluation - Precast Round Crested Concrete Weir |  | 8d | 2016-11-21 | 2016-11-29 | PR-Z3-LW-LS-118-0030 | 205.8d | 0d |  |  | OK | 1.2.6.20 | PROC | PROC |
| PR-Z3-LW-LS-118-0050 |  | PO - Precast Round Crested Concrete Weir |  | 11.2d | 2016-11-30 | 2016-12-13 | PR-Z3-LW-LS-118-0040 | 205.8d | 0d |  |  | OK | 1.2.6.20 | PROC | PROC |
| PR-Z3-LW-LS-118-0060 |  | NMR 601 - Precast Round Crested Concrete Weir |  | 12d | 2016-12-13 | 2016-12-27 | PR-Z3-LW-LS-118-0050 | 205.8d | 0d |  |  | OK | 1.2.6.20 | PROC | PROC |
| PR-Z3-LW-LS-118-0070 |  | NMR 602 - Precast Round Crested Concrete Weir |  | 12d | 2016-12-27 | 2017-01-10 | PR-Z3-LW-LS-118-0060 | 205.8d | 0d |  |  | OK | 1.2.6.20 | PROC | PROC |
| PR-Z3-LW-LS-118-0080 |  | Start of Material Delivery - Precast Round Crested Concrete Weir | milestone | 0d | 2017-04-25 | 2017-04-25 | PR-Z3-LW-LS-118-0070 FS+90d | 205.8d | 0d |  |  | OK | 1.2.6.20 | PROC | PROC |
| PR-Z3-LW-LS-118-0090 |  | Complete Material Delivery - Precast Round Crested Concrete Weir |  | 18d | 2017-04-25 | 2017-05-16 | PR-Z3-LW-LS-118-0080 | 205.8d | 0d | Precast Round Crested Concrete Weir [208 Lm] | 103,607.07 | OK | 1.2.6.20 | PROC | PROC |
| PR-Z3-LW-LS-118-0100 |  | NMR 603 - Precast Round Crested Concrete Weir |  | 8d | 2017-05-16 | 2017-05-25 | PR-Z3-LW-LS-118-0090 | 205.8d | 123.6d |  |  | OK | 1.2.6.20 | PROC | PROC |
|  | 3 | **Fitness & playground equipment** |  |  | 2016-09-24 | 2017-05-31 |  |  |  |  |  |  |  |  |  |
|  | 1 | **Playground Equipment Accessories** |  |  | 2016-09-24 | 2017-05-31 |  |  |  |  |  |  |  |  |  |
| PR-Z3-LW-LS-119-0010 |  | RFQ - Playground Equipment Accessories |  | 5.6d | 2016-09-24 | 2016-09-29 | PROC-GE-GE-GE-0010 FS+35d | 141d | 0d |  |  | OK | 1.2.6.30 | PROC | PROC |
| PR-Z3-LW-LS-119-0020 |  | Material Submittal - Playground Equipment Accessories |  | 8d | 2016-11-24 | 2016-12-04 | PR-Z3-LW-LS-119-0010 FS+48d | 141d | 0d |  |  | OK | 1.2.6.30 | PROC | PROC |
| PR-Z3-LW-LS-119-0030 |  | Material Approval - Playground Equipment Accessories |  | 11.2d | 2016-12-04 | 2016-12-17 | PR-Z3-LW-LS-119-0020 | 141d | 0d |  |  | OK | 1.2.6.30 | PROC | PROC |
| PR-Z3-LW-LS-119-0040 |  | Technical Evaluation - Playground Equipment Accessories |  | 8d | 2016-12-18 | 2016-12-26 | PR-Z3-LW-LS-119-0030 | 141d | 0d |  |  | OK | 1.2.6.30 | PROC | PROC |
| PR-Z3-LW-LS-119-0050 |  | PO - Playground Equipment Accessories |  | 8d | 2016-12-27 | 2017-01-04 | PR-Z3-LW-LS-119-0040 | 141d | 0d |  |  | OK | 1.2.6.30 | PROC | PROC |
| PR-Z3-LW-LS-119-0060 |  | NMR 601 - Playground Equipment Accessories |  | 12d | 2017-01-05 | 2017-01-18 | PR-Z3-LW-LS-119-0050 | 141d | 0d |  |  | OK | 1.2.6.30 | PROC | PROC |
| PR-Z3-LW-LS-119-0070 |  | NMR 602 - Playground Equipment Accessories |  | 12d | 2017-01-19 | 2017-02-01 | PR-Z3-LW-LS-119-0060 | 141d | 0d |  |  | OK | 1.2.6.30 | PROC | PROC |
| PR-Z3-LW-LS-119-0080 |  | Start of Material Delivery - Playground Equipment Accessories | milestone | 0d | 2017-05-02 | 2017-05-02 | PR-Z3-LW-LS-119-0070 FS+76d | 141d | 0d |  |  | OK | 1.2.6.30 | PROC | PROC |
| PR-Z3-LW-LS-119-0090 |  | Complete Material Delivery - Playground Equipment Accessories |  | 18d | 2017-05-02 | 2017-05-22 | PR-Z3-LW-LS-119-0080 | 200d | 0d | Play Ground Equipment Accessories [1 LS] | 46,680.1 | OK | 1.2.6.30 | PROC | PROC |
| PR-Z3-LW-LS-119-0100 |  | NMR 603 - Playground Equipment Accessories |  | 8d | 2017-05-23 | 2017-05-31 | PR-Z3-LW-LS-119-0090 | 200d | 117.8d |  |  | OK | 1.2.6.30 | PROC | PROC |
|  | 2 | **Fitness Equipment Accessories** |  |  | 2016-09-24 | 2017-05-31 |  |  |  |  |  |  |  |  |  |
| PR-Z3-LW-LS-120-0010 |  | RFQ - Fitness Equipment Accessories |  | 5.6d | 2016-09-24 | 2016-09-29 | PR-Z3-LW-LS-119-0010 SS, PROC-GE-GE-GE-0010 | 141d | 0d |  |  | OK | 1.2.6.30 | PROC | PROC |
| PR-Z3-LW-LS-120-0020 |  | Material Submittal - Fitness Equipment Accessories |  | 8d | 2016-11-24 | 2016-12-04 | PR-Z3-LW-LS-120-0010 FS+48d | 141d | 0d |  |  | OK | 1.2.6.30 | PROC | PROC |
| PR-Z3-LW-LS-120-0030 |  | Material Approval - Fitness Equipment Accessories |  | 11.2d | 2016-12-04 | 2016-12-17 | PR-Z3-LW-LS-120-0020 | 141d | 0d |  |  | OK | 1.2.6.30 | PROC | PROC |
| PR-Z3-LW-LS-120-0040 |  | Technical Evaluation - Fitness Equipment Accessories |  | 8d | 2016-12-18 | 2016-12-26 | PR-Z3-LW-LS-120-0030 | 141d | 0d |  |  | OK | 1.2.6.30 | PROC | PROC |
| PR-Z3-LW-LS-120-0050 |  | PO - Fitness Equipment Accessories |  | 8d | 2016-12-27 | 2017-01-04 | PR-Z3-LW-LS-120-0040 | 141d | 0d |  |  | OK | 1.2.6.30 | PROC | PROC |
| PR-Z3-LW-LS-120-0060 |  | NMR 601 - Fitness Equipment Accessories |  | 12d | 2017-01-05 | 2017-01-18 | PR-Z3-LW-LS-120-0050 | 141d | 0d |  |  | OK | 1.2.6.30 | PROC | PROC |
| PR-Z3-LW-LS-120-0070 |  | NMR 602 - Fitness Equipment Accessories |  | 12d | 2017-01-19 | 2017-02-01 | PR-Z3-LW-LS-120-0060 | 141d | 0d |  |  | OK | 1.2.6.30 | PROC | PROC |
| PR-Z3-LW-LS-120-0080 |  | Start of Material Delivery - Fitness Equipment Accessories | milestone | 0d | 2017-05-02 | 2017-05-02 | PR-Z3-LW-LS-120-0070 FS+76d | 141d | 0d |  |  | OK | 1.2.6.30 | PROC | PROC |
| PR-Z3-LW-LS-120-0090 |  | Complete Material Delivery - Fitness Equipment Accessories |  | 18d | 2017-05-02 | 2017-05-22 | PR-Z3-LW-LS-120-0080 | 200d | 0d | Fitness Equipment Accessories [1 LS] | 22,998.49 | OK | 1.2.6.30 | PROC | PROC |
| PR-Z3-LW-LS-120-0100 |  | NMR 603 - Fitness Equipment Accessories |  | 8d | 2017-05-23 | 2017-05-31 | PR-Z3-LW-LS-120-0090 | 200d | 117.8d |  |  | OK | 1.2.6.30 | PROC | PROC |

Notes:
- PR-Z3-LW-LS-118-0090: Expenses: (New Expense Item) 103607
- PR-Z3-LW-LS-119-0090: Expenses: (New Expense Item) 46680.1
- PR-Z3-LW-LS-120-0090: Expenses: (New Expense Item) 22998.5

| ID | WBS | Activity | Type | Duration | Start | Finish | Predecessors | Total float | Free float | Resources | Cost | Wajid | RPI_P2 - BOQ ITEMS | RPI_P2 - PROCUREMENT | RPI_P2 - PHASE |
| --- | --- | --- | --- | --- | --- | --- | --- | --- | --- | --- | --- | --- | --- | --- | --- |
|  | 5 | **UTILITIES AND SERVICE WORKS** |  |  | 2016-08-21 | 2017-04-11 |  |  |  |  |  |  |  |  |  |
|  | 1 | **Potable and Fire Water System and related material** |  |  | 2016-08-21 | 2017-04-11 |  |  |  |  |  |  |  |  |  |
|  | 3 | **RTR Pipes & Fittings** |  |  | 2016-08-23 | 2017-03-21 |  |  |  |  |  |  |  |  |  |
| PR-Z3-UT-PW-121-0010 |  | RFQ - RTR Pipes & Fittings |  | 12d | 2016-08-23 | 2016-09-05 | PROC-GE-GE-GE-0010 FS+12d | 76.2d | 0d |  |  | OK | 1.2.7.10 | PROC | PROC |
| PR-Z3-UT-PW-121-0020 |  | Material Submittal - RTR Pipes & Fittings |  | 8d | 2016-09-06 | 2016-09-20 | PR-Z3-UT-PW-121-0010 | 92.6d | 0d |  |  | OK | 1.2.7.10 | PROC | PROC |
| PR-Z3-UT-PW-121-0030 |  | Material Approval - RTR Pipes & Fittings |  | 11.2d | 2016-09-20 | 2016-10-03 | PR-Z3-UT-PW-121-0020 | 92.6d | 0d |  |  | OK | 1.2.7.10 | PROC | PROC |
| PR-Z3-UT-PW-121-0040 |  | Technical Evaluation - RTR Pipes & Fittings |  | 8d | 2016-10-03 | 2016-10-12 | PR-Z3-UT-PW-121-0030 | 92.6d | 0d |  |  | OK | 1.2.7.10 | PROC | PROC |
| PR-Z3-UT-PW-121-0050 |  | PO - RTR Pipes & Fittings |  | 11.2d | 2016-10-12 | 2016-10-25 | PR-Z3-UT-PW-121-0040 | 92.6d | 0d |  |  | OK | 1.2.7.10 | PROC | PROC |
| PR-Z3-UT-PW-121-0060 |  | NMR 601 - RTR Pipes & Fittings |  | 12d | 2016-10-25 | 2016-11-08 | PR-Z3-UT-PW-121-0050 | 92.6d | 0d |  |  | OK | 1.2.7.10 | PROC | PROC |
| PR-Z3-UT-PW-121-0070 |  | NMR 602 - RTR Pipes & Fittings |  | 12d | 2016-11-08 | 2016-11-22 | PR-Z3-UT-PW-121-0060 | 92.6d | 0d |  |  | OK | 1.2.7.10 | PROC | PROC |
| PR-Z3-UT-PW-121-0080 |  | Start of Material Delivery - RTR Pipes & Fittings | milestone | 0d | 2016-12-19 | 2016-12-19 | PR-Z3-UT-PW-121-0070 FS+22.4d | 92.6d | 0d |  |  | OK | 1.2.7.10 | PROC | PROC |
| PR-Z3-UT-PW-121-0090 |  | Complete Material Delivery - RTR Pipes & Fittings |  | 72d | 2016-12-19 | 2017-03-12 | PR-Z3-UT-PW-121-0080 | 261d | 0d | RTR Pipes & Fittings [2504 Lm] | 773,706.97 | OK | 1.2.7.10 | PROC | PROC |
| PR-Z3-UT-PW-121-0100 |  | NMR 603 - RTR Pipes & Fittings |  | 8d | 2017-03-13 | 2017-03-21 | PR-Z3-UT-PW-121-0090 | 261d | 178.8d |  |  | OK | 1.2.7.10 | PROC | PROC |
|  | 4 | **Concrete for Thrust Blocks** |  |  | 2016-08-27 | 2017-01-18 |  |  |  |  |  |  |  |  |  |
| PR-Z3-UT-PW-122-0010 |  | RFQ - Concrete for Thrust Blocks & Valve Support |  | 12d | 2016-08-27 | 2016-09-08 | PROC-GE-GE-GE-0010 FS+15d | 314d | 0d |  |  | OK | 1.2.7.10 | PROC | PROC |
| PR-Z3-UT-PW-122-0020 |  | Material Submittal - Concrete for Thrust Blocks & Valve Support |  | 5.6d | 2016-09-10 | 2016-09-20 | PR-Z3-UT-PW-122-0010 | 314d | 0d |  |  | OK | 1.2.7.10 | PROC | PROC |
| PR-Z3-UT-PW-122-0030 |  | Material Approval - Concrete for Thrust Blocks & Valve Support |  | 5.6d | 2016-09-20 | 2016-09-27 | PR-Z3-UT-PW-122-0020 | 314d | 0d |  |  | OK | 1.2.7.10 | PROC | PROC |
| PR-Z3-UT-PW-122-0040 |  | Technical Evaluation - Concrete for Thrust Blocks & Valve Support |  | 4.8d | 2016-09-27 | 2016-10-03 | PR-Z3-UT-PW-122-0030 | 314d | 0d |  |  | OK | 1.2.7.10 | PROC | PROC |
| PR-Z3-UT-PW-122-0050 |  | PO - Concrete for Thrust Blocks & Valve Support |  | 8d | 2016-10-03 | 2016-10-12 | PR-Z3-UT-PW-122-0040 | 314d | 0d |  |  | OK | 1.2.7.10 | PROC | PROC |
| PR-Z3-UT-PW-122-0060 |  | NMR 601 - Concrete for Thrust Blocks & Valve Support |  | 2.4d | 2016-10-12 | 2016-10-15 | PR-Z3-UT-PW-122-0050 | 314d | 0d |  |  | OK | 1.2.7.10 | PROC | PROC |
| PR-Z3-UT-PW-122-0070 |  | NMR 602 - Concrete for Thrust Blocks & Valve Support |  | 2.4d | 2016-10-15 | 2016-10-17 | PR-Z3-UT-PW-122-0060 | 314d | 0d |  |  | OK | 1.2.7.10 | PROC | PROC |
| PR-Z3-UT-PW-122-0080 |  | Start of Material Delivery - Concrete for Thrust Blocks & Valve Support | milestone | 0d | 2016-10-18 | 2016-10-18 | PR-Z3-UT-PW-122-0070 | 314d | 0d |  |  | OK | 1.2.7.10 | PROC | PROC |
| PR-Z3-UT-PW-122-0090 |  | Complete Material Delivery - Concrete for Thrust Blocks & Valve Support |  | 72d | 2016-10-18 | 2017-01-09 | PR-Z3-UT-PW-122-0080 | 314d | 0d | Ready Mix Concrete [1 m³] | 18,827.72 | OK | 1.2.7.10 | PROC | PROC |
| PR-Z3-UT-PW-122-0100 |  | NMR 603 - Concrete for Thrust Blocks & Valve Support |  | 8d | 2017-01-10 | 2017-01-18 | PR-Z3-UT-PW-122-0090 | 314d | 231.8d |  |  | OK | 1.2.7.10 | PROC | PROC |

Notes:
- PR-Z3-UT-PW-121-0090: Expenses: (New Expense Item) 773707
- PR-Z3-UT-PW-122-0090: Expenses: (New Expense Item) 18827.7

| ID | WBS | Activity | Type | Duration | Start | Finish | Predecessors | Total float | Free float | Resources | Cost | Wajid | RPI_P2 - BOQ ITEMS | RPI_P2 - PROCUREMENT | RPI_P2 - PHASE |
| --- | --- | --- | --- | --- | --- | --- | --- | --- | --- | --- | --- | --- | --- | --- | --- |
|  | 5 | **Fire Hydrants including Break check valve** |  |  | 2016-09-07 | 2017-04-11 |  |  |  |  |  |  |  |  |  |
| PR-Z3-UT-PW-123-0010 |  | RFQ - Fire Hydrants including Break Check Value |  | 12d | 2016-09-07 | 2016-09-26 | PROC-GE-GE-GE-0010 FS+25d | 67d | 0d |  |  | OK | 1.2.7.10 | PROC | PROC |
| PR-Z3-UT-PW-123-0020 |  | Material Submittal - Fire Hydrants including Break Check Value |  | 8d | 2016-09-26 | 2016-10-05 | PR-Z3-UT-PW-123-0010 | 116.2d | 0d |  |  | OK | 1.2.7.10 | PROC | PROC |
| PR-Z3-UT-PW-123-0030 |  | Material Approval - Fire Hydrants including Break Check Value |  | 11.2d | 2016-10-05 | 2016-10-18 | PR-Z3-UT-PW-123-0020 | 116.2d | 0d |  |  | OK | 1.2.7.10 | PROC | PROC |
| PR-Z3-UT-PW-123-0040 |  | Technical Evaluation - Fire Hydrants including Break Check Value |  | 8d | 2016-10-18 | 2016-10-27 | PR-Z3-UT-PW-123-0030 | 116.2d | 0d |  |  | OK | 1.2.7.10 | PROC | PROC |
| PR-Z3-UT-PW-123-0050 |  | PO - Fire Hydrants including Break Check Value |  | 11.2d | 2016-10-27 | 2016-11-09 | PR-Z3-UT-PW-123-0040 | 116.2d | 0d |  |  | OK | 1.2.7.10 | PROC | PROC |
| PR-Z3-UT-PW-123-0060 |  | NMR 601 - Fire Hydrants including Break Check Value |  | 18d | 2016-11-09 | 2016-11-30 | PR-Z3-UT-PW-123-0050 | 116.2d | 0d |  |  | OK | 1.2.7.10 | PROC | PROC |
| PR-Z3-UT-PW-123-0070 |  | NMR 602 - Fire Hydrants including Break Check Value |  | 18d | 2016-11-30 | 2016-12-21 | PR-Z3-UT-PW-123-0060 | 116.2d | 0d |  |  | OK | 1.2.7.10 | PROC | PROC |
| PR-Z3-UT-PW-123-0080 |  | Start of Material Delivery - Fire Hydrants including Break Check Value | milestone | 0d | 2017-02-05 | 2017-02-05 | PR-Z3-UT-PW-123-0070 FS+39.2d | 116.2d | 0d |  |  | OK | 1.2.7.10 | PROC | PROC |
| PR-Z3-UT-PW-123-0090 |  | Complete Material Delivery - Fire Hydrants including Break Check Value |  | 48d | 2017-02-05 | 2017-04-02 | PR-Z3-UT-PW-123-0080 | 243.2d | 0d | Fire Hydrant including Break Check Valves [39 ea] | 634,185.53 | OK | 1.2.7.10 | PROC | PROC |
| PR-Z3-UT-PW-123-0100 |  | NMR 603 - Fire Hydrants including Break Check Value |  | 8d | 2017-04-02 | 2017-04-11 | PR-Z3-UT-PW-123-0090 | 243.2d | 161d |  |  | OK | 1.2.7.10 | PROC | PROC |
|  | 6 | **Gate Valves Direct Burried with Extension Spindle & Surface Box** |  |  | 2016-09-19 | 2017-03-07 |  |  |  |  |  |  |  |  |  |
| PR-Z3-UT-PW-124-0010 |  | RFQ - Gate Valves Direct Burried with Extension Spindle & Surface Box |  | 12d | 2016-09-19 | 2016-10-03 | PROC-GE-GE-GE-0010 FS+14.4d, PR-Z3-UT-PW-123-0010 SS+6d | 67d | 0d |  |  | OK | 1.2.7.10 | PROC | PROC |
| PR-Z3-UT-PW-124-0020 |  | Material Submittal - Gate Valves Direct Burried with Extension Spindle & Surface Box |  | 8d | 2016-10-03 | 2016-10-12 | PR-Z3-UT-PW-124-0010 | 67d | 0d |  |  | OK | 1.2.7.10 | PROC | PROC |
| PR-Z3-UT-PW-124-0030 |  | Material Approval - Gate Valves Direct Burried with Extension Spindle & Surface Box |  | 11.2d | 2016-10-12 | 2016-10-25 | PR-Z3-UT-PW-124-0020 | 67d | 0d |  |  | OK | 1.2.7.10 | PROC | PROC |
| PR-Z3-UT-PW-124-0040 |  | Technical Evaluation - Gate Valves Direct Burried with Extension Spindle & Surface Box |  | 8d | 2016-10-25 | 2016-11-03 | PR-Z3-UT-PW-124-0030 | 67d | 0d |  |  | OK | 1.2.7.10 | PROC | PROC |
| PR-Z3-UT-PW-124-0050 |  | PO - Gate Valves Direct Burried with Extension Spindle & Surface Box |  | 12d | 2016-11-03 | 2016-11-17 | PR-Z3-UT-PW-124-0040 | 67d | 0d |  |  | OK | 1.2.7.10 | PROC | PROC |
| PR-Z3-UT-PW-124-0060 |  | NMR 601 - Gate Valves Direct Burried with Extension Spindle & Surface Box |  | 18d | 2016-11-17 | 2016-12-08 | PR-Z3-UT-PW-124-0050 | 67d | 0d |  |  | OK | 1.2.7.10 | PROC | PROC |
| PR-Z3-UT-PW-124-0070 |  | NMR 602 - Gate Valves Direct Burried with Extension Spindle & Surface Box |  | 18d | 2016-12-08 | 2016-12-29 | PR-Z3-UT-PW-124-0060 | 67d | 0d |  |  | OK | 1.2.7.10 | PROC | PROC |
| PR-Z3-UT-PW-124-0080 |  | Start of Material Delivery - Gate Valves Direct Burried with Extension Spindle & Surface Box | milestone | 0d | 2017-02-12 | 2017-02-12 | PR-Z3-UT-PW-124-0070 FS+38.4d | 67d | 0d |  |  | OK | 1.2.7.10 | PROC | PROC |
| PR-Z3-UT-PW-124-0090 |  | Complete Material Delivery - Gate Valves Direct Burried with Extension Spindle & Surface Box |  | 12d | 2017-02-12 | 2017-02-26 | PR-Z3-UT-PW-124-0080 | 273.2d | 0d | Gate Valves Direct Buried with Extension Spindle & Surface Box [71 ea] | 378,123.44 | OK | 1.2.7.10 | PROC | PROC |
| PR-Z3-UT-PW-124-0100 |  | NMR 603 - Gate Valves Direct Burried with Extension Spindle & Surface Box |  | 8d | 2017-02-26 | 2017-03-07 | PR-Z3-UT-PW-124-0090 | 273.2d | 191d |  |  | OK | 1.2.7.10 | PROC | PROC |
|  | 7 | **Metallic Flanges, Pipe & Fittings for Fire Hydrants** |  |  | 2016-09-19 | 2017-03-07 |  |  |  |  |  |  |  |  |  |
| PR-Z3-UT-PW-125-0010 |  | RFQ - Metallic Flanges, Pipe & Fittings for Fire Hydrants |  | 12d | 2016-09-19 | 2016-10-03 | PROC-GE-GE-GE-0010 FS+4d, PR-Z3-UT-PW-124-0010 SS | 114.2d | 0d |  |  | OK | 1.2.7.10 | PROC | PROC |
| PR-Z3-UT-PW-125-0020 |  | Material Submittal - Metallic Flanges, Pipe & Fittings for Fire Hydrants |  | 8d | 2016-10-03 | 2016-10-12 | PR-Z3-UT-PW-125-0010 | 114.2d | 0d |  |  | OK | 1.2.7.10 | PROC | PROC |
| PR-Z3-UT-PW-125-0030 |  | Material Approval - Metallic Flanges, Pipe & Fittings for Fire Hydrants |  | 11.2d | 2016-10-12 | 2016-10-25 | PR-Z3-UT-PW-125-0020 | 114.2d | 0d |  |  | OK | 1.2.7.10 | PROC | PROC |
| PR-Z3-UT-PW-125-0040 |  | Technical Evaluation - Metallic Flanges, Pipe & Fittings for Fire Hydrants |  | 8d | 2016-10-25 | 2016-11-03 | PR-Z3-UT-PW-125-0030 | 114.2d | 0d |  |  | OK | 1.2.7.10 | PROC | PROC |
| PR-Z3-UT-PW-125-0050 |  | PO - Metallic Flanges, Pipe & Fittings for Fire Hydrants |  | 11.2d | 2016-11-03 | 2016-11-16 | PR-Z3-UT-PW-125-0040 | 114.2d | 0d |  |  | OK | 1.2.7.10 | PROC | PROC |
| PR-Z3-UT-PW-125-0060 |  | NMR 601 - Metallic Flanges, Pipe & Fittings for Fire Hydrants |  | 18d | 2016-11-16 | 2016-12-07 | PR-Z3-UT-PW-125-0050 | 114.2d | 0d |  |  | OK | 1.2.7.10 | PROC | PROC |
| PR-Z3-UT-PW-125-0070 |  | NMR 602 - Metallic Flanges, Pipe & Fittings for Fire Hydrants |  | 18d | 2016-12-07 | 2016-12-28 | PR-Z3-UT-PW-125-0060 | 114.2d | 0d |  |  | OK | 1.2.7.10 | PROC | PROC |
| PR-Z3-UT-PW-125-0080 |  | Start of Material Delivery - Metallic Flanges, Pipe & Fittings for Fire Hydrants | milestone | 0d | 2017-02-12 | 2017-02-12 | PR-Z3-UT-PW-125-0070 FS+39.2d | 114.2d | 0d |  |  | OK | 1.2.7.10 | PROC | PROC |
| PR-Z3-UT-PW-125-0090 |  | Complete Material Delivery - Metallic Flanges, Pipe & Fittings for Fire Hydrants |  | 12d | 2017-02-12 | 2017-02-26 | PR-Z3-UT-PW-125-0080 | 273.2d | 0d | Metallic Flanges, Pipes & Fittings (for Fire Hydrants) [71 Set] | 244,536.26 | OK | 1.2.7.10 | PROC | PROC |
| PR-Z3-UT-PW-125-0100 |  | NMR 603 - Metallic Flanges, Pipe & Fittings for Fire Hydrants |  | 8d | 2017-02-26 | 2017-03-07 | PR-Z3-UT-PW-125-0090 | 273.2d | 191d |  |  | OK | 1.2.7.10 | PROC | PROC |

Notes:
- PR-Z3-UT-PW-123-0090: Expenses: (New Expense Item) 634186
- PR-Z3-UT-PW-124-0090: Expenses: (New Expense Item) 378123
- PR-Z3-UT-PW-125-0090: Expenses: (New Expense Item) 244536

| ID | WBS | Activity | Type | Duration | Start | Finish | Predecessors | Total float | Free float | Resources | Cost | Wajid | RPI_P2 - BOQ ITEMS | RPI_P2 - PROCUREMENT | RPI_P2 - PHASE |
| --- | --- | --- | --- | --- | --- | --- | --- | --- | --- | --- | --- | --- | --- | --- | --- |
|  | 8 | **Guard Post for Fire Hydrants** |  |  | 2016-10-13 | 2017-03-08 |  |  |  |  |  |  |  |  |  |
| PR-Z3-UT-PW-126-0010 |  | RFQ - Guard Post for Fire Hydrants |  | 5.6d | 2016-10-13 | 2016-10-19 | PR-Z3-UT-PW-125-0010 SS, PROC-GE-GE-GE-0010 FS+52d | 117.2d | 0d |  |  | OK | 1.2.7.10 | PROC | PROC |
| PR-Z3-UT-PW-126-0020 |  | Material Submittal - Guard Post for Fire Hydrants |  | 8d | 2016-10-19 | 2016-10-29 | PR-Z3-UT-PW-126-0010 | 117.2d | 0d |  |  | OK | 1.2.7.10 | PROC | PROC |
| PR-Z3-UT-PW-126-0030 |  | Material Approval - Guard Post for Fire Hydrants |  | 11.2d | 2016-10-29 | 2016-11-10 | PR-Z3-UT-PW-126-0020 | 117.2d | 0d |  |  | OK | 1.2.7.10 | PROC | PROC |
| PR-Z3-UT-PW-126-0040 |  | Technical Evaluation - Guard Post for Fire Hydrants |  | 8d | 2016-11-12 | 2016-11-20 | PR-Z3-UT-PW-126-0030 | 117.2d | 0d |  |  | OK | 1.2.7.10 | PROC | PROC |
| PR-Z3-UT-PW-126-0050 |  | PO - Guard Post for Fire Hydrants |  | 11.2d | 2016-11-21 | 2016-12-04 | PR-Z3-UT-PW-126-0040 | 117.2d | 0d |  |  | OK | 1.2.7.10 | PROC | PROC |
| PR-Z3-UT-PW-126-0060 |  | NMR 601 - Guard Post for Fire Hydrants |  | 12d | 2016-12-04 | 2016-12-18 | PR-Z3-UT-PW-126-0050 | 117.2d | 0d |  |  | OK | 1.2.7.10 | PROC | PROC |
| PR-Z3-UT-PW-126-0070 |  | NMR 602 - Guard Post for Fire Hydrants |  | 12d | 2016-12-18 | 2017-01-01 | PR-Z3-UT-PW-126-0060 | 117.2d | 0d |  |  | OK | 1.2.7.10 | PROC | PROC |
| PR-Z3-UT-PW-126-0080 |  | Start of Material Delivery - Guard Post for Fire Hydrants | milestone | 0d | 2017-02-13 | 2017-02-13 | PR-Z3-UT-PW-126-0070 FS+37.6d | 117.2d | 0d |  |  | OK | 1.2.7.10 | PROC | PROC |
| PR-Z3-UT-PW-126-0090 |  | Complete Material Delivery - Guard Post for Fire Hydrants |  | 12d | 2017-02-13 | 2017-02-27 | PR-Z3-UT-PW-126-0080 | 272.2d | 0d | Guard Posts for Fire Hydrants [142 ea] | 100,862.8 | OK | 1.2.7.10 | PROC | PROC |
| PR-Z3-UT-PW-126-0100 |  | NMR 603 - Guard Post for Fire Hydrants |  | 8d | 2017-02-27 | 2017-03-08 | PR-Z3-UT-PW-126-0090 | 272.2d | 190d |  |  | OK | 1.2.7.10 | PROC | PROC |
|  | 9 | **Dismantling Joints - Valve Box Fittings** |  |  | 2016-08-21 | 2017-02-15 |  |  |  |  |  |  |  |  |  |
| PR-Z3-UT-PW-127-0010 |  | RFQ - Dismantling Joints (Valve Box Fittings) |  | 18d | 2016-08-21 | 2016-09-15 | PROC-GE-GE-GE-0010 FS+10.4d | 100.8d | 0d |  |  | OK | 1.2.7.10 | PROC | PROC |
| PR-Z3-UT-PW-127-0020 |  | Material Submittal - Dismantling Joints (Valve Box Fittings) |  | 8d | 2016-09-15 | 2016-09-25 | PR-Z3-UT-PW-127-0010 | 100.8d | 0d |  |  | OK | 1.2.7.10 | PROC | PROC |
| PR-Z3-UT-PW-127-0030 |  | Material Approval - Dismantling Joints (Valve Box Fittings) |  | 11.2d | 2016-09-25 | 2016-10-08 | PR-Z3-UT-PW-127-0020 | 100.8d | 0d |  |  | OK | 1.2.7.10 | PROC | PROC |
| PR-Z3-UT-PW-127-0040 |  | Technical Evaluation - Dismantling Joints (Valve Box Fittings) |  | 8d | 2016-10-08 | 2016-10-17 | PR-Z3-UT-PW-127-0030 | 100.8d | 0d |  |  | OK | 1.2.7.10 | PROC | PROC |
| PR-Z3-UT-PW-127-0050 |  | PO - Dismantling Joints (Valve Box Fittings) |  | 11.2d | 2016-10-17 | 2016-10-30 | PR-Z3-UT-PW-127-0040 | 100.8d | 0d |  |  | OK | 1.2.7.10 | PROC | PROC |
| PR-Z3-UT-PW-127-0060 |  | NMR 601 - Dismantling Joints (Valve Box Fittings) |  | 12d | 2016-10-31 | 2016-11-13 | PR-Z3-UT-PW-127-0050 | 100.8d | 0d |  |  | OK | 1.2.7.10 | PROC | PROC |
| PR-Z3-UT-PW-127-0070 |  | NMR 602 - Dismantling Joints (Valve Box Fittings) |  | 12d | 2016-11-14 | 2016-11-27 | PR-Z3-UT-PW-127-0060 | 100.8d | 0d |  |  | OK | 1.2.7.10 | PROC | PROC |
| PR-Z3-UT-PW-127-0080 |  | Start of Material Delivery - Dismantling Joints (Valve Box Fittings) | milestone | 0d | 2017-01-02 | 2017-01-02 | PR-Z3-UT-PW-127-0070 FS+30.4d | 100.8d | 0d |  |  | OK | 1.2.7.10 | PROC | PROC |
| PR-Z3-UT-PW-127-0090 |  | Complete Material Delivery - Dismantling Joints (Valve Box Fittings) |  | 30d | 2017-01-02 | 2017-02-06 | PR-Z3-UT-PW-127-0080 | 290.6d | 0d | Dismantling Joints - Valve Box Fittings [84 ea] | 1,299,387.55 | OK | 1.2.7.10 | PROC | PROC |
| PR-Z3-UT-PW-127-0100 |  | NMR 603 - Dismantling Joints (Valve Box Fittings) |  | 8d | 2017-02-06 | 2017-02-15 | PR-Z3-UT-PW-127-0090 | 290.6d | 208.4d |  |  | OK | 1.2.7.10 | PROC | PROC |
|  | 10 | **Gate Valves, Butterfly Valves, Drain Valves, Air Release Valves** |  |  | 2016-08-25 | 2017-03-01 |  |  |  |  |  |  |  |  |  |
| PR-Z3-UT-PW-128-0010 |  | RFQ - Gate Valves, Butterfly Valves, Drain Valves, Air Release Valves |  | 18d | 2016-08-25 | 2016-09-20 | PROC-GE-GE-GE-0010 FS+14.4d | 118d | 0d |  |  | OK | 1.2.7.10 | PROC | PROC |
| PR-Z3-UT-PW-128-0020 |  | Material Submittal - Gate Valves, Butterfly Valves, Drain Valves, Air Release Valves |  | 8d | 2016-09-20 | 2016-09-29 | PR-Z3-UT-PW-128-0010 | 118d | 0d |  |  | OK | 1.2.7.10 | PROC | PROC |
| PR-Z3-UT-PW-128-0030 |  | Material Approval - Gate Valves, Butterfly Valves, Drain Valves, Air Release Valves |  | 11.2d | 2016-09-29 | 2016-10-12 | PR-Z3-UT-PW-128-0020 | 118d | 0d |  |  | OK | 1.2.7.10 | PROC | PROC |
| PR-Z3-UT-PW-128-0040 |  | Technical Evaluation - Gate Valves, Butterfly Valves, Drain Valves, Air Release Valves |  | 8d | 2016-10-12 | 2016-10-22 | PR-Z3-UT-PW-128-0030 | 118d | 0d |  |  | OK | 1.2.7.10 | PROC | PROC |
| PR-Z3-UT-PW-128-0050 |  | PO - Gate Valves, Butterfly Valves, Drain Valves, Air Release Valves |  | 11.2d | 2016-10-22 | 2016-11-03 | PR-Z3-UT-PW-128-0040 | 118d | 0d |  |  | OK | 1.2.7.10 | PROC | PROC |
| PR-Z3-UT-PW-128-0060 |  | NMR 601 - Gate Valves, Butterfly Valves, Drain Valves, Air Release Valves |  | 12d | 2016-11-05 | 2016-11-17 | PR-Z3-UT-PW-128-0050 | 118d | 0d |  |  | OK | 1.2.7.10 | PROC | PROC |
| PR-Z3-UT-PW-128-0070 |  | NMR 602 - Gate Valves, Butterfly Valves, Drain Valves, Air Release Valves |  | 12d | 2016-11-19 | 2016-12-01 | PR-Z3-UT-PW-128-0060 | 118d | 0d |  |  | OK | 1.2.7.10 | PROC | PROC |
| PR-Z3-UT-PW-128-0080 |  | Start of Material Delivery - Gate Valves, Butterfly Valves, Drain Valves, Air Release Valves | milestone | 0d | 2017-01-16 | 2017-01-16 | PR-Z3-UT-PW-128-0070 FS+38.4d | 118d | 0d |  |  | OK | 1.2.7.10 | PROC | PROC |
| PR-Z3-UT-PW-128-0090 |  | Complete Material Delivery - Gate Valves, Butterfly Valves, Drain Valves, Air Release Valves |  | 30d | 2017-01-16 | 2017-02-20 | PR-Z3-UT-PW-128-0080 | 278.6d | 0d | Gate Valves, Butterfly Valves, Drain Valves, Air Release Valves [208 ea] | 1,876,676.35 | OK | 1.2.7.10 | PROC | PROC |
| PR-Z3-UT-PW-128-0100 |  | NMR 603 - Gate Valves, Butterfly Valves, Drain Valves, Air Release Valves |  | 8d | 2017-02-20 | 2017-03-01 | PR-Z3-UT-PW-128-0090 | 278.6d | 196.4d |  |  | OK | 1.2.7.10 | PROC | PROC |

Notes:
- PR-Z3-UT-PW-126-0090: Expenses: (New Expense Item) 100863
- PR-Z3-UT-PW-127-0090: Expenses: (New Expense Item) 1299388
- PR-Z3-UT-PW-128-0090: Expenses: (New Expense Item) 1876676

| ID | WBS | Activity | Type | Duration | Start | Finish | Predecessors | Total float | Free float | Resources | Cost | Wajid | RPI_P2 - BOQ ITEMS | RPI_P2 - PROCUREMENT | RPI_P2 - PHASE |
| --- | --- | --- | --- | --- | --- | --- | --- | --- | --- | --- | --- | --- | --- | --- | --- |
|  | 11 | **DI Flanged Short Pipes, DI Tee, Puddle Sleeves, Nut & Bolts, Gaskets, Guages, Blind Flanges** |  |  | 2016-08-21 | 2017-02-15 |  |  |  |  |  |  |  |  |  |
| PR-Z3-UT-PW-129-0010 |  | RFQ - DI Flanged Short Pipes, DI Tee, Puddle Sleeves, Nut & Bolts, Gaskets, Guages, Blind Flanges |  | 18d | 2016-08-21 | 2016-09-15 | PROC-GE-GE-GE-0010 FS+10.4d | 100.8d | 0d |  |  | OK | 1.2.7.10 | PROC | PROC |
| PR-Z3-UT-PW-129-0020 |  | Material Submittal - DI Flanged Short Pipes, DI Tee, Puddle Sleeves, Nut & Bolts, ... |  | 8d | 2016-09-15 | 2016-09-25 | PR-Z3-UT-PW-129-0010 | 100.8d | 0d |  |  | OK | 1.2.7.10 | PROC | PROC |
| PR-Z3-UT-PW-129-0030 |  | Material Approval - DI Flanged Short Pipes, DI Tee, Puddle Sleeves, Nut & Bolts, ... |  | 11.2d | 2016-09-25 | 2016-10-08 | PR-Z3-UT-PW-129-0020 | 100.8d | 0d |  |  | OK | 1.2.7.10 | PROC | PROC |
| PR-Z3-UT-PW-129-0040 |  | Technical Evaluation - DI Flanged Short Pipes, DI Tee, Puddle Sleeves, Nut & Bolts, ... |  | 8d | 2016-10-08 | 2016-10-17 | PR-Z3-UT-PW-129-0030 | 100.8d | 0d |  |  | OK | 1.2.7.10 | PROC | PROC |
| PR-Z3-UT-PW-129-0050 |  | PO - DI Flanged Short Pipes, DI Tee, Puddle Sleeves, Nut & Bolts, ... |  | 11.2d | 2016-10-17 | 2016-10-30 | PR-Z3-UT-PW-129-0040 | 100.8d | 0d |  |  | OK | 1.2.7.10 | PROC | PROC |
| PR-Z3-UT-PW-129-0060 |  | NMR 601 - DI Flanged Short Pipes, DI Tee, Puddle Sleeves, Nut & Bolts, ... |  | 12d | 2016-10-31 | 2016-11-13 | PR-Z3-UT-PW-129-0050 | 100.8d | 0d |  |  | OK | 1.2.7.10 | PROC | PROC |
| PR-Z3-UT-PW-129-0070 |  | NMR 602 - DI Flanged Short Pipes, DI Tee, Puddle Sleeves, Nut & Bolts, ... |  | 12d | 2016-11-14 | 2016-11-27 | PR-Z3-UT-PW-129-0060 | 100.8d | 0d |  |  | OK | 1.2.7.10 | PROC | PROC |
| PR-Z3-UT-PW-129-0080 |  | Start of Material Delivery - DI Flanged Short Pipes, DI Tee, Puddle Sleeves, Nut & Bolts, ... | milestone | 0d | 2017-01-02 | 2017-01-02 | PR-Z3-UT-PW-129-0070 FS+30.4d | 100.8d | 0d |  |  | OK | 1.2.7.10 | PROC | PROC |
| PR-Z3-UT-PW-129-0090 |  | Complete Material Delivery - DI Flanged Short Pipes, DI Tee, Puddle Sleeves, Nut & Bolts, ... |  | 30d | 2017-01-02 | 2017-02-06 | PR-Z3-UT-PW-129-0080 | 290.6d | 0d | DI Flanged Short Pipes, DI Tee, Puddle Sleeves, Nuts & Bolts, Gasket [5620 ea] | 2,106,162.11 | OK | 1.2.7.10 | PROC | PROC |
| PR-Z3-UT-PW-129-0100 |  | NMR 603 - DI Flanged Short Pipes, DI Tee, Puddle Sleeves, Nut & Bolts, ... |  | 8d | 2017-02-06 | 2017-02-15 | PR-Z3-UT-PW-129-0090 | 290.6d | 208.4d |  |  | OK | 1.2.7.10 | PROC | PROC |
|  | 12 | **UPVC Tee & Elbows** |  |  | 2016-09-03 | 2017-01-11 |  |  |  |  |  |  |  |  |  |
| PR-Z3-UT-PW-130-0010 |  | RFQ - UPVC Tee & Elbows |  | 12d | 2016-09-03 | 2016-09-21 | PROC-GE-GE-GE-0010 FS+21d | 320d | 0d |  |  | OK | 1.2.7.10 | PROC | PROC |
| PR-Z3-UT-PW-130-0020 |  | Material Submittal - UPVC Tee & Elbows |  | 8d | 2016-09-21 | 2016-10-01 | PR-Z3-UT-PW-130-0010 | 320d | 0d |  |  | OK | 1.2.7.10 | PROC | PROC |
| PR-Z3-UT-PW-130-0030 |  | Material Approval - UPVC Tee & Elbows |  | 11.2d | 2016-10-01 | 2016-10-13 | PR-Z3-UT-PW-130-0020 | 320d | 0d |  |  | OK | 1.2.7.10 | PROC | PROC |
| PR-Z3-UT-PW-130-0040 |  | Technical Evaluation - UPVC Tee & Elbows |  | 8d | 2016-10-13 | 2016-10-23 | PR-Z3-UT-PW-130-0030 | 320d | 0d |  |  | OK | 1.2.7.10 | PROC | PROC |
| PR-Z3-UT-PW-130-0050 |  | PO - UPVC Tee & Elbows |  | 11.2d | 2016-10-23 | 2016-11-05 | PR-Z3-UT-PW-130-0040 | 320d | 0d |  |  | OK | 1.2.7.10 | PROC | PROC |
| PR-Z3-UT-PW-130-0060 |  | NMR 601 - UPVC Tee & Elbows |  | 4.8d | 2016-11-05 | 2016-11-10 | PR-Z3-UT-PW-130-0050 | 320d | 0d |  |  | OK | 1.2.7.10 | PROC | PROC |
| PR-Z3-UT-PW-130-0070 |  | NMR 602 - UPVC Tee & Elbows |  | 4.8d | 2016-11-10 | 2016-11-16 | PR-Z3-UT-PW-130-0060 | 320d | 0d |  |  | OK | 1.2.7.10 | PROC | PROC |
| PR-Z3-UT-PW-130-0080 |  | Start of Material Delivery - UPVC Tee & Elbows | milestone | 0d | 2016-12-20 | 2016-12-20 | PR-Z3-UT-PW-130-0070 FS+28.8d | 320d | 0d |  |  | OK | 1.2.7.10 | PROC | PROC |
| PR-Z3-UT-PW-130-0090 |  | Complete Material Delivery - UPVC Tee & Elbows |  | 12d | 2016-12-20 | 2017-01-02 | PR-Z3-UT-PW-130-0080 | 320d | 0d | UPVC Tee & Elbows [6 ea] | 15,640.84 | OK | 1.2.7.10 | PROC | PROC |
| PR-Z3-UT-PW-130-0100 |  | NMR 603 - UPVC Tee & Elbows |  | 8d | 2017-01-03 | 2017-01-11 | PR-Z3-UT-PW-130-0090 | 320d | 237.8d |  |  | OK | 1.2.7.10 | PROC | PROC |
|  | 13 | **GI Steel Ladders** |  |  | 2016-09-18 | 2017-02-18 |  |  |  |  |  |  |  |  |  |
| PR-Z3-UT-PW-131-0010 |  | RFQ - GI Steel Ladders |  | 12d | 2016-09-18 | 2016-10-02 | PROC-GE-GE-GE-0010 FS+30d | 288.6d | 0d |  |  | OK | 1.2.7.10 | PROC | PROC |
| PR-Z3-UT-PW-131-0020 |  | Material Submittal - GI Steel Ladders |  | 8d | 2016-10-02 | 2016-10-11 | PR-Z3-UT-PW-131-0010 | 288.6d | 0d |  |  | OK | 1.2.7.10 | PROC | PROC |
| PR-Z3-UT-PW-131-0030 |  | Material Approval - GI Steel Ladders |  | 11.2d | 2016-10-11 | 2016-10-24 | PR-Z3-UT-PW-131-0020 | 288.6d | 0d |  |  | OK | 1.2.7.10 | PROC | PROC |
| PR-Z3-UT-PW-131-0040 |  | Technical Evaluation - GI Steel Ladders |  | 8d | 2016-10-24 | 2016-11-02 | PR-Z3-UT-PW-131-0030 | 288.6d | 0d |  |  | OK | 1.2.7.10 | PROC | PROC |
| PR-Z3-UT-PW-131-0050 |  | PO - GI Steel Ladders |  | 11.2d | 2016-11-02 | 2016-11-15 | PR-Z3-UT-PW-131-0040 | 288.6d | 0d |  |  | OK | 1.2.7.10 | PROC | PROC |
| PR-Z3-UT-PW-131-0060 |  | NMR 601 - GI Steel Ladders |  | 12d | 2016-11-15 | 2016-11-29 | PR-Z3-UT-PW-131-0050 | 288.6d | 0d |  |  | OK | 1.2.7.10 | PROC | PROC |
| PR-Z3-UT-PW-131-0070 |  | NMR 602 - GI Steel Ladders |  | 12d | 2016-11-29 | 2016-12-13 | PR-Z3-UT-PW-131-0060 | 288.6d | 0d |  |  | OK | 1.2.7.10 | PROC | PROC |
| PR-Z3-UT-PW-131-0080 |  | Start of Material Delivery - GI Steel Ladders | milestone | 0d | 2017-01-25 | 2017-01-25 | PR-Z3-UT-PW-131-0070 FS+36.8d | 288.6d | 0d |  |  | OK | 1.2.7.10 | PROC | PROC |
| PR-Z3-UT-PW-131-0090 |  | Complete Material Delivery - GI Steel Ladders |  | 12d | 2017-01-25 | 2017-02-08 | PR-Z3-UT-PW-131-0080 | 288.6d | 0d | GI Steel Ladders [3 ea] | 710.3 | OK | 1.2.7.10 | PROC | PROC |
| PR-Z3-UT-PW-131-0100 |  | NMR 603 - GI Steel Ladders |  | 8d | 2017-02-08 | 2017-02-18 | PR-Z3-UT-PW-131-0090 | 288.6d | 206.4d |  |  | OK | 1.2.7.10 | PROC | PROC |

Notes:
- PR-Z3-UT-PW-129-0090: Expenses: (New Expense Item) 2106162
- PR-Z3-UT-PW-130-0090: Expenses: (New Expense Item) 15640.8
- PR-Z3-UT-PW-131-0090: Expenses: (New Expense Item) 710.3

| ID | WBS | Activity | Type | Duration | Start | Finish | Predecessors | Total float | Free float | Resources | Cost | Wajid | RPI_P2 - BOQ ITEMS | RPI_P2 - PROCUREMENT | RPI_P2 - PHASE |
| --- | --- | --- | --- | --- | --- | --- | --- | --- | --- | --- | --- | --- | --- | --- | --- |
|  | 2 | **Seawater System and related material** |  |  | 2016-08-21 | 2017-03-15 |  |  |  |  |  |  |  |  |  |
|  | 1 | **RTR Pipes & Fittings including end caps** |  |  | 2016-08-23 | 2017-02-18 |  |  |  |  |  |  |  |  |  |
| PR-Z3-UT-PW-132-0010 |  | RFQ - RTR Pipes & Fittings including end caps |  | 12d | 2016-08-23 | 2016-09-05 | PROC-GE-GE-GE-0010 FS+3.2d, PR-Z3-UT-PW-121-0010 SS | 76.2d | 0d |  |  | OK | 1.2.7.20 | PROC | PROC |
| PR-Z3-UT-PW-132-0020 |  | Material Submittal - RTR Pipes & Fittings including end caps |  | 8d | 2016-09-06 | 2016-09-20 | PR-Z3-UT-PW-132-0010 | 76.2d | 0d |  |  | OK | 1.2.7.20 | PROC | PROC |
| PR-Z3-UT-PW-132-0030 |  | Material Approval - RTR Pipes & Fittings including end caps |  | 11.2d | 2016-09-20 | 2016-10-03 | PR-Z3-UT-PW-132-0020 | 76.2d | 0d |  |  | OK | 1.2.7.20 | PROC | PROC |
| PR-Z3-UT-PW-132-0040 |  | Technical Evaluation - RTR Pipes & Fittings including end caps |  | 8d | 2016-10-03 | 2016-10-12 | PR-Z3-UT-PW-132-0030 | 76.2d | 0d |  |  | OK | 1.2.7.20 | PROC | PROC |
| PR-Z3-UT-PW-132-0050 |  | PO - RTR Pipes & Fittings including end caps |  | 11.2d | 2016-10-12 | 2016-10-25 | PR-Z3-UT-PW-132-0040 | 76.2d | 0d |  |  | OK | 1.2.7.20 | PROC | PROC |
| PR-Z3-UT-PW-132-0060 |  | NMR 601 - RTR Pipes & Fittings including end caps |  | 12d | 2016-10-25 | 2016-11-08 | PR-Z3-UT-PW-132-0050 | 76.2d | 0d |  |  | OK | 1.2.7.20 | PROC | PROC |
| PR-Z3-UT-PW-132-0070 |  | NMR 602 - RTR Pipes & Fittings including end caps |  | 12d | 2016-11-08 | 2016-11-22 | PR-Z3-UT-PW-132-0060 | 76.2d | 0d |  |  | OK | 1.2.7.20 | PROC | PROC |
| PR-Z3-UT-PW-132-0080 |  | Start of Material Delivery - RTR Pipes & Fittings including end caps | milestone | 0d | 2016-12-14 | 2016-12-14 | PR-Z3-UT-PW-132-0070 FS+19.2d | 76.2d | 0d |  |  | OK | 1.2.7.20 | PROC | PROC |
| PR-Z3-UT-PW-132-0090 |  | Complete Material Delivery - RTR Pipes & Fittings including end caps |  | 48d | 2016-12-14 | 2017-02-08 | PR-Z3-UT-PW-132-0080 | 288.2d | 0d | RTR Pipes & Fittings [472 Lm] | 604,161.03 | OK | 1.2.7.20 | PROC | PROC |
| PR-Z3-UT-PW-132-0100 |  | NMR 603 - RTR Pipes & Fittings including end caps |  | 8d | 2017-02-08 | 2017-02-18 | PR-Z3-UT-PW-132-0090 | 288.2d | 206d |  |  | OK | 1.2.7.20 | PROC | PROC |
|  | 2 | **Concrete for Valve Chamber & Thrust Blocks** |  |  | 2016-08-22 | 2017-03-15 |  |  |  |  |  |  |  |  |  |
| PR-Z3-UT-PW-133-0010 |  | RFQ - Concrete for Valve Chamber & Thrust Blocks |  | 18d | 2016-08-22 | 2016-09-17 | PROC-GE-GE-GE-0010 FS+11.2d | 248.8d | 0d |  |  | OK | 1.2.7.20 | PROC | PROC |
| PR-Z3-UT-PW-133-0020 |  | Material Submittal - Concrete for Valve Chamber & Thrust Blocks |  | 5.6d | 2016-09-17 | 2016-09-22 | PR-Z3-UT-PW-133-0010 | 248.8d | 0d |  |  | OK | 1.2.7.20 | PROC | PROC |
| PR-Z3-UT-PW-133-0030 |  | Material Approval - Concrete for Valve Chamber & Thrust Blocks |  | 5.6d | 2016-09-24 | 2016-09-29 | PR-Z3-UT-PW-133-0020 | 248.8d | 0d |  |  | OK | 1.2.7.20 | PROC | PROC |
| PR-Z3-UT-PW-133-0040 |  | Technical Evaluation - Concrete for Valve Chamber & Thrust Blocks |  | 4d | 2016-09-29 | 2016-10-04 | PR-Z3-UT-PW-133-0030 | 248.8d | 0d |  |  | OK | 1.2.7.20 | PROC | PROC |
| PR-Z3-UT-PW-133-0050 |  | PO - Concrete for Valve Chamber & Thrust Blocks |  | 8d | 2016-10-04 | 2016-10-13 | PR-Z3-UT-PW-133-0040 | 248.8d | 0d |  |  | OK | 1.2.7.20 | PROC | PROC |
| PR-Z3-UT-PW-133-0060 |  | NMR 601 - Concrete for Valve Chamber & Thrust Blocks |  | 1.6d | 2016-10-13 | 2016-10-16 | PR-Z3-UT-PW-133-0050 | 248.8d | 0d |  |  | OK | 1.2.7.20 | PROC | PROC |
| PR-Z3-UT-PW-133-0070 |  | NMR 602 - Concrete for Valve Chamber & Thrust Blocks |  | 1.6d | 2016-10-16 | 2016-10-17 | PR-Z3-UT-PW-133-0060 | 248.8d | 0d |  |  | OK | 1.2.7.20 | PROC | PROC |
| PR-Z3-UT-PW-133-0080 |  | Start of Material Delivery - Concrete for Valve Chamber & Thrust Blocks | milestone | 0d | 2016-10-17 | 2016-10-17 | PR-Z3-UT-PW-133-0070 | 248.8d | 0d |  |  | OK | 1.2.7.20 | PROC | PROC |
| PR-Z3-UT-PW-133-0090 |  | Complete Material Delivery - Concrete for Valve Chamber & Thrust Blocks |  | 120d | 2016-10-17 | 2017-03-06 | PR-Z3-UT-PW-133-0080 | 266.2d | 0d | Ready Mix Concrete [1 m³] | 111,198.49 | OK | 1.2.7.20 | PROC | PROC |
| PR-Z3-UT-PW-133-0100 |  | NMR 603 - Concrete for Valve Chamber & Thrust Blocks |  | 8d | 2017-03-06 | 2017-03-15 | PR-Z3-UT-PW-133-0090 | 266.2d | 184d |  |  | OK | 1.2.7.20 | PROC | PROC |
|  | 7 | **Butterfly Valves, Air Release Valves, Gate Valves** |  |  | 2016-08-25 | 2017-03-01 |  |  |  |  |  |  |  |  |  |
| PR-Z3-UT-PW-134-0010 |  | RFQ - Butterfly Valves, Air Release Valves, Gate Valves |  | 18d | 2016-08-25 | 2016-09-20 | PROC-GE-GE-GE-0010 FS+14.4d | 188.2d | 0d |  |  | OK | 1.2.7.20 | PROC | PROC |
| PR-Z3-UT-PW-134-0020 |  | Material Submittal - Butterfly Valves, Air Release Valves, Gate Valves |  | 8d | 2016-09-20 | 2016-09-29 | PR-Z3-UT-PW-134-0010 | 188.2d | 0d |  |  | OK | 1.2.7.20 | PROC | PROC |
| PR-Z3-UT-PW-134-0030 |  | Material Approval - Butterfly Valves, Air Release Valves, Gate Valves |  | 11.2d | 2016-09-29 | 2016-10-12 | PR-Z3-UT-PW-134-0020 | 188.2d | 0d |  |  | OK | 1.2.7.20 | PROC | PROC |
| PR-Z3-UT-PW-134-0040 |  | Technical Evaluation - Butterfly Valves, Air Release Valves, Gate Valves |  | 8d | 2016-10-12 | 2016-10-22 | PR-Z3-UT-PW-134-0030 | 188.2d | 0d |  |  | OK | 1.2.7.20 | PROC | PROC |
| PR-Z3-UT-PW-134-0050 |  | PO - Butterfly Valves, Air Release Valves, Gate Valves |  | 11.2d | 2016-10-22 | 2016-11-03 | PR-Z3-UT-PW-134-0040 | 188.2d | 0d |  |  | OK | 1.2.7.20 | PROC | PROC |
| PR-Z3-UT-PW-134-0060 |  | NMR 601 - Butterfly Valves, Air Release Valves, Gate Valves |  | 12d | 2016-11-05 | 2016-11-17 | PR-Z3-UT-PW-134-0050 | 188.2d | 0d |  |  | OK | 1.2.7.20 | PROC | PROC |
| PR-Z3-UT-PW-134-0070 |  | NMR 602 - Butterfly Valves, Air Release Valves, Gate Valves |  | 12d | 2016-11-19 | 2016-12-01 | PR-Z3-UT-PW-134-0060 | 188.2d | 0d |  |  | OK | 1.2.7.20 | PROC | PROC |
| PR-Z3-UT-PW-134-0080 |  | Start of Material Delivery - Butterfly Valves, Air Release Valves, Gate Valves | milestone | 0d | 2017-01-16 | 2017-01-16 | PR-Z3-UT-PW-134-0070 FS+38.4d | 188.2d | 0d |  |  | OK | 1.2.7.20 | PROC | PROC |
| PR-Z3-UT-PW-134-0090 |  | Complete Material Delivery - Butterfly Valves, Air Release Valves, Gate Valves |  | 30d | 2017-01-16 | 2017-02-20 | PR-Z3-UT-PW-134-0080 | 278.6d | 0d | Gate Valves, Butterfly Valves, Drain Valves, Air Release Valves [79 ea] | 974,758.56 | OK | 1.2.7.20 | PROC | PROC |
| PR-Z3-UT-PW-134-0100 |  | NMR 603 - Butterfly Valves, Air Release Valves, Gate Valves |  | 8d | 2017-02-20 | 2017-03-01 | PR-Z3-UT-PW-134-0090 | 278.6d | 196.4d |  |  | OK | 1.2.7.20 | PROC | PROC |

Notes:
- PR-Z3-UT-PW-132-0090: Expenses: (New Expense Item) 604161
- PR-Z3-UT-PW-133-0090: Expenses: (New Expense Item) 111198
- PR-Z3-UT-PW-134-0090: Expenses: (New Expense Item) 974759

| ID | WBS | Activity | Type | Duration | Start | Finish | Predecessors | Total float | Free float | Resources | Cost | Wajid | RPI_P2 - BOQ ITEMS | RPI_P2 - PROCUREMENT | RPI_P2 - PHASE |
| --- | --- | --- | --- | --- | --- | --- | --- | --- | --- | --- | --- | --- | --- | --- | --- |
|  | 8 | **Dismantling Joints** |  |  | 2016-08-21 | 2017-02-15 |  |  |  |  |  |  |  |  |  |
| PR-Z3-UT-PW-135-0010 |  | RFQ - Dismantling Joints |  | 18d | 2016-08-21 | 2016-09-15 | PR-Z3-UT-PW-127-0010 SS, PROC-GE-GE-GE-0010 FS+10.4d | 199.2d | 0d |  |  | OK | 1.2.7.20 | PROC | PROC |
| PR-Z3-UT-PW-135-0020 |  | Material Submittal - Dismantling Joints |  | 8d | 2016-09-15 | 2016-09-25 | PR-Z3-UT-PW-135-0010 | 199.2d | 0d |  |  | OK | 1.2.7.20 | PROC | PROC |
| PR-Z3-UT-PW-135-0030 |  | Material Approval - Dismantling Joints |  | 11.2d | 2016-09-25 | 2016-10-08 | PR-Z3-UT-PW-135-0020 | 199.2d | 0d |  |  | OK | 1.2.7.20 | PROC | PROC |
| PR-Z3-UT-PW-135-0040 |  | Technical Evaluation - Dismantling Joints |  | 8d | 2016-10-08 | 2016-10-17 | PR-Z3-UT-PW-135-0030 | 199.2d | 0d |  |  | OK | 1.2.7.20 | PROC | PROC |
| PR-Z3-UT-PW-135-0050 |  | PO - Dismantling Joints |  | 11.2d | 2016-10-17 | 2016-10-30 | PR-Z3-UT-PW-135-0040 | 199.2d | 0d |  |  | OK | 1.2.7.20 | PROC | PROC |
| PR-Z3-UT-PW-135-0060 |  | NMR 601 - Dismantling Joints |  | 12d | 2016-10-31 | 2016-11-13 | PR-Z3-UT-PW-135-0050 | 199.2d | 0d |  |  | OK | 1.2.7.20 | PROC | PROC |
| PR-Z3-UT-PW-135-0070 |  | NMR 602 - Dismantling Joints |  | 12d | 2016-11-14 | 2016-11-27 | PR-Z3-UT-PW-135-0060 | 199.2d | 0d |  |  | OK | 1.2.7.20 | PROC | PROC |
| PR-Z3-UT-PW-135-0080 |  | Start of Material Delivery - Dismantling Joints | milestone | 0d | 2017-01-02 | 2017-01-02 | PR-Z3-UT-PW-135-0070 FS+30.4d | 199.2d | 0d |  |  | OK | 1.2.7.20 | PROC | PROC |
| PR-Z3-UT-PW-135-0090 |  | Complete Material Delivery - Dismantling Joints |  | 30d | 2017-01-02 | 2017-02-06 | PR-Z3-UT-PW-135-0080 | 290.6d | 0d | Dismantling Joints - Valve Box Fittings [34 ea] | 619,727.99 | OK | 1.2.7.20 | PROC | PROC |
| PR-Z3-UT-PW-135-0100 |  | NMR 603 - Dismantling Joints |  | 8d | 2017-02-06 | 2017-02-15 | PR-Z3-UT-PW-135-0090 | 290.6d | 208.4d |  |  | OK | 1.2.7.20 | PROC | PROC |
|  | 9 | **Puddle Sleeves, Metal Supports, Nut & Bolts, Pressure Indicators, Blind Flanges** |  |  | 2016-08-30 | 2017-02-23 |  |  |  |  |  |  |  |  |  |
| PR-Z3-UT-PW-136-0010 |  | RFQ - Puddle Sleeves, Metal Supports, Nut & Bolts, Pressure Indicators, Blind Flanges |  | 18d | 2016-08-30 | 2016-09-25 | PROC-GE-GE-GE-0010 FS+18d | 283d | 0d |  |  | OK | 1.2.7.20 | PROC | PROC |
| PR-Z3-UT-PW-136-0020 |  | Material Submittal - Puddle Sleeves, Metal Supports, Nut & Bolts, Pressure Indicators, Blind Flanges |  | 8d | 2016-09-25 | 2016-10-04 | PR-Z3-UT-PW-136-0010 | 283d | 0d |  |  | OK | 1.2.7.20 | PROC | PROC |
| PR-Z3-UT-PW-136-0030 |  | Material Approval - Puddle Sleeves, Metal Supports, Nut & Bolts, Pressure Indicators, Blind Flanges |  | 11.2d | 2016-10-04 | 2016-10-17 | PR-Z3-UT-PW-136-0020 | 283d | 0d |  |  | OK | 1.2.7.20 | PROC | PROC |
| PR-Z3-UT-PW-136-0040 |  | Technical Evaluation - Puddle Sleeves, Metal Supports, Nut & Bolts, Pressure Indicators, Blind Flanges |  | 8d | 2016-10-17 | 2016-10-26 | PR-Z3-UT-PW-136-0030 | 283d | 0d |  |  | OK | 1.2.7.20 | PROC | PROC |
| PR-Z3-UT-PW-136-0050 |  | PO - Puddle Sleeves, Metal Supports, Nut & Bolts, Pressure Indicators, Blind Flanges |  | 11.2d | 2016-10-26 | 2016-11-08 | PR-Z3-UT-PW-136-0040 | 283d | 0d |  |  | OK | 1.2.7.20 | PROC | PROC |
| PR-Z3-UT-PW-136-0060 |  | NMR 601 - Puddle Sleeves, Metal Supports, Nut & Bolts, Pressure Indicators, Blind Flanges |  | 12d | 2016-11-08 | 2016-11-22 | PR-Z3-UT-PW-136-0050 | 283d | 0d |  |  | OK | 1.2.7.20 | PROC | PROC |
| PR-Z3-UT-PW-136-0070 |  | NMR 602 - Puddle Sleeves, Metal Supports, Nut & Bolts, Pressure Indicators, Blind Flanges |  | 12d | 2016-11-22 | 2016-12-06 | PR-Z3-UT-PW-136-0060 | 283d | 0d |  |  | OK | 1.2.7.20 | PROC | PROC |
| PR-Z3-UT-PW-136-0080 |  | Start of Material Delivery - Puddle Sleeves, Metal Supports, Nut & Bolts, Pressure Indicators, Blind Flanges | milestone | 0d | 2017-01-11 | 2017-01-11 | PR-Z3-UT-PW-136-0070 FS+30.4d | 283d | 0d |  |  | OK | 1.2.7.20 | PROC | PROC |
| PR-Z3-UT-PW-136-0090 |  | Complete Material Delivery - Puddle Sleeves, Metal Supports, Nut & Bolts, Pressure Indicators, Blind Flanges |  | 30d | 2017-01-11 | 2017-02-14 | PR-Z3-UT-PW-136-0080 | 283d | 0d | DI Flanged Short Pipes, DI Tee, Puddle Sleeves, Nuts & Bolts, Gasket [68 ea] | 238,845.36 | OK | 1.2.7.20 | PROC | PROC |
| PR-Z3-UT-PW-136-0100 |  | NMR 603 - Puddle Sleeves, Metal Supports, Nut & Bolts, Pressure Indicators, Blind Flanges |  | 8d | 2017-02-15 | 2017-02-23 | PR-Z3-UT-PW-136-0090 | 283d | 200.8d |  |  | OK | 1.2.7.20 | PROC | PROC |
|  | 10 | **Chlorination Skid** |  |  | 2016-09-24 | 2017-03-04 |  |  |  |  |  |  |  |  |  |
| PR-Z3-UT-PW-137-0010 |  | RFQ - Chlorination Skid |  | 12d | 2016-09-24 | 2016-10-08 | PROC-GE-GE-GE-0010 FS+35d | 276.4d | 0d |  |  | OK | 1.2.7.20 | PROC | PROC |
| PR-Z3-UT-PW-137-0020 |  | Material Submittal - Chlorination Skid |  | 8d | 2016-10-08 | 2016-10-17 | PR-Z3-UT-PW-137-0010 | 276.4d | 0d |  |  | OK | 1.2.7.20 | PROC | PROC |
| PR-Z3-UT-PW-137-0030 |  | Material Approval - Chlorination Skid |  | 11.2d | 2016-10-17 | 2016-10-30 | PR-Z3-UT-PW-137-0020 | 276.4d | 0d |  |  | OK | 1.2.7.20 | PROC | PROC |
| PR-Z3-UT-PW-137-0040 |  | Technical Evaluation - Chlorination Skid |  | 8d | 2016-10-30 | 2016-11-08 | PR-Z3-UT-PW-137-0030 | 276.4d | 0d |  |  | OK | 1.2.7.20 | PROC | PROC |
| PR-Z3-UT-PW-137-0050 |  | PO - Chlorination Skid |  | 11.2d | 2016-11-08 | 2016-11-21 | PR-Z3-UT-PW-137-0040 | 276.4d | 0d |  |  | OK | 1.2.7.20 | PROC | PROC |
| PR-Z3-UT-PW-137-0060 |  | NMR 601 - Chlorination Skid |  | 12d | 2016-11-21 | 2016-12-05 | PR-Z3-UT-PW-137-0050 | 276.4d | 0d |  |  | OK | 1.2.7.20 | PROC | PROC |
| PR-Z3-UT-PW-137-0070 |  | NMR 602 - Chlorination Skid |  | 12d | 2016-12-05 | 2016-12-19 | PR-Z3-UT-PW-137-0060 | 276.4d | 0d |  |  | OK | 1.2.7.20 | PROC | PROC |
| PR-Z3-UT-PW-137-0080 |  | Start of Material Delivery - Chlorination Skid | milestone | 0d | 2017-02-08 | 2017-02-08 | PR-Z3-UT-PW-137-0070 FS+44d | 276.4d | 0d |  |  | OK | 1.2.7.20 | PROC | PROC |
| PR-Z3-UT-PW-137-0090 |  | Complete Material Delivery - Chlorination Skid |  | 12d | 2017-02-08 | 2017-02-22 | PR-Z3-UT-PW-137-0080 | 276.4d | 0d | Cholorination Skid [1 ea] | 127,083.99 | OK | 1.2.7.20 | PROC | PROC |
| PR-Z3-UT-PW-137-0100 |  | NMR 603 - Chlorination Skid |  | 8d | 2017-02-22 | 2017-03-04 | PR-Z3-UT-PW-137-0090 | 276.4d | 194.2d |  |  | OK | 1.2.7.20 | PROC | PROC |

Notes:
- PR-Z3-UT-PW-135-0090: Expenses: (New Expense Item) 619728
- PR-Z3-UT-PW-136-0090: Expenses: (New Expense Item) 238845
- PR-Z3-UT-PW-137-0090: Expenses: (New Expense Item) 127084

| ID | WBS | Activity | Type | Duration | Start | Finish | Predecessors | Total float | Free float | Resources | Cost | Wajid | RPI_P2 - BOQ ITEMS | RPI_P2 - PROCUREMENT | RPI_P2 - PHASE |
| --- | --- | --- | --- | --- | --- | --- | --- | --- | --- | --- | --- | --- | --- | --- | --- |
|  | 3 | **Sanitary Sewer System and Related Material** |  |  | 2016-08-21 | 2017-03-26 |  |  |  |  |  |  |  |  |  |
|  | 1 | **UPVC Pipe & Fittings including Blind Flanges** |  |  | 2016-08-25 | 2017-03-11 |  |  |  |  |  |  |  |  |  |
| PR-Z3-UT-PW-138-0010 |  | RFQ - UPVC Pipe & Fittings including Blind Flanges |  | 18d | 2016-08-25 | 2016-09-20 | PROC-GE-GE-GE-0010 FS+14.4d | 270.2d | 0d |  |  | OK | 1.2.7.30 | PROC | PROC |
| PR-Z3-UT-PW-138-0020 |  | Material Submittal - UPVC Pipe & Fittings including Blind Flanges |  | 8d | 2016-09-20 | 2016-09-29 | PR-Z3-UT-PW-138-0010 | 270.2d | 0d |  |  | OK | 1.2.7.30 | PROC | PROC |
| PR-Z3-UT-PW-138-0030 |  | Material Approval - UPVC Pipe & Fittings including Blind Flanges |  | 11.2d | 2016-09-29 | 2016-10-12 | PR-Z3-UT-PW-138-0020 | 270.2d | 0d |  |  | OK | 1.2.7.30 | PROC | PROC |
| PR-Z3-UT-PW-138-0040 |  | Technical Evaluation - UPVC Pipe & Fittings including Blind Flanges |  | 8d | 2016-10-12 | 2016-10-22 | PR-Z3-UT-PW-138-0030 | 270.2d | 0d |  |  | OK | 1.2.7.30 | PROC | PROC |
| PR-Z3-UT-PW-138-0050 |  | PO - UPVC Pipe & Fittings including Blind Flanges |  | 11.2d | 2016-10-22 | 2016-11-03 | PR-Z3-UT-PW-138-0040 | 270.2d | 0d |  |  | OK | 1.2.7.30 | PROC | PROC |
| PR-Z3-UT-PW-138-0060 |  | NMR 601 - UPVC Pipe & Fittings including Blind Flanges |  | 12d | 2016-11-05 | 2016-11-17 | PR-Z3-UT-PW-138-0050 | 270.2d | 0d |  |  | OK | 1.2.7.30 | PROC | PROC |
| PR-Z3-UT-PW-138-0070 |  | NMR 602 - UPVC Pipe & Fittings including Blind Flanges |  | 12d | 2016-11-19 | 2016-12-01 | PR-Z3-UT-PW-138-0060 | 270.2d | 0d |  |  | OK | 1.2.7.30 | PROC | PROC |
| PR-Z3-UT-PW-138-0080 |  | Start of Material Delivery - UPVC Pipe & Fittings including Blind Flanges | milestone | 0d | 2017-01-04 | 2017-01-04 | PR-Z3-UT-PW-138-0070 FS+28.8d | 270.2d | 0d |  |  | OK | 1.2.7.30 | PROC | PROC |
| PR-Z3-UT-PW-138-0090 |  | Complete Material Delivery - UPVC Pipe & Fittings including Blind Flanges |  | 48d | 2017-01-04 | 2017-03-01 | PR-Z3-UT-PW-138-0080 | 270.2d | 0d | UPVC Pipes & Fittings including Blind Flanges [4098 Lm] | 1,407,336.21 | OK | 1.2.7.30 | PROC | PROC |
| PR-Z3-UT-PW-138-0100 |  | NMR 603 - UPVC Pipe & Fittings including Blind Flanges |  | 8d | 2017-03-01 | 2017-03-11 | PR-Z3-UT-PW-138-0090 | 270.2d | 188d |  |  | OK | 1.2.7.30 | PROC | PROC |
|  | 2 | **RTR Pipes & Fittings** |  |  | 2016-08-23 | 2017-02-25 |  |  |  |  |  |  |  |  |  |
| PR-Z3-UT-PW-139-0010 |  | RFQ - RTR Pipes & Fittings |  | 18d | 2016-08-23 | 2016-09-18 | PROC-GE-GE-GE-0010 FS+12d | 282.2d | 0d |  |  | OK | 1.2.7.30 | PROC | PROC |
| PR-Z3-UT-PW-139-0020 |  | Material Submittal - RTR Pipes & Fittings |  | 8d | 2016-09-18 | 2016-09-27 | PR-Z3-UT-PW-139-0010 | 282.2d | 0d |  |  | OK | 1.2.7.30 | PROC | PROC |
| PR-Z3-UT-PW-139-0030 |  | Material Approval - RTR Pipes & Fittings |  | 11.2d | 2016-09-27 | 2016-10-10 | PR-Z3-UT-PW-139-0020 | 282.2d | 0d |  |  | OK | 1.2.7.30 | PROC | PROC |
| PR-Z3-UT-PW-139-0040 |  | Technical Evaluation - RTR Pipes & Fittings |  | 8d | 2016-10-10 | 2016-10-19 | PR-Z3-UT-PW-139-0030 | 282.2d | 0d |  |  | OK | 1.2.7.30 | PROC | PROC |
| PR-Z3-UT-PW-139-0050 |  | PO - RTR Pipes & Fittings |  | 11.2d | 2016-10-19 | 2016-11-01 | PR-Z3-UT-PW-139-0040 | 282.2d | 0d |  |  | OK | 1.2.7.30 | PROC | PROC |
| PR-Z3-UT-PW-139-0060 |  | NMR 601 - RTR Pipes & Fittings |  | 12d | 2016-11-01 | 2016-11-15 | PR-Z3-UT-PW-139-0050 | 282.2d | 0d |  |  | OK | 1.2.7.30 | PROC | PROC |
| PR-Z3-UT-PW-139-0070 |  | NMR 602 - RTR Pipes & Fittings |  | 12d | 2016-11-15 | 2016-11-29 | PR-Z3-UT-PW-139-0060 | 282.2d | 0d |  |  | OK | 1.2.7.30 | PROC | PROC |
| PR-Z3-UT-PW-139-0080 |  | Start of Material Delivery - RTR Pipes & Fittings | milestone | 0d | 2016-12-21 | 2016-12-21 | PR-Z3-UT-PW-139-0070 FS+19.2d | 282.2d | 0d |  |  | OK | 1.2.7.30 | PROC | PROC |
| PR-Z3-UT-PW-139-0090 |  | Complete Material Delivery - RTR Pipes & Fittings |  | 48d | 2016-12-21 | 2017-02-15 | PR-Z3-UT-PW-139-0080 | 282.2d | 0d | RTR Pipes & Fittings [12 Lm] | 51,177.21 | OK | 1.2.7.30 | PROC | PROC |
| PR-Z3-UT-PW-139-0100 |  | NMR 603 - RTR Pipes & Fittings |  | 8d | 2017-02-15 | 2017-02-25 | PR-Z3-UT-PW-139-0090 | 282.2d | 200d |  |  | OK | 1.2.7.30 | PROC | PROC |
|  | 3 | **Flanged Gate Valves** |  |  | 2016-08-30 | 2017-03-26 |  |  |  |  |  |  |  |  |  |
| PR-Z3-UT-PW-140-0010 |  | RFQ - Flanged Gate Valves |  | 18d | 2016-08-30 | 2016-09-25 | PROC-GE-GE-GE-0010 FS+18d | 98d | 0d |  |  | OK | 1.2.7.30 | PROC | PROC |
| PR-Z3-UT-PW-140-0020 |  | Material Submittal - Flanged Gate Valves |  | 8d | 2016-09-25 | 2016-10-04 | PR-Z3-UT-PW-140-0010 | 98d | 0d |  |  | OK | 1.2.7.30 | PROC | PROC |
| PR-Z3-UT-PW-140-0030 |  | Material Approval - Flanged Gate Valves |  | 11.2d | 2016-10-04 | 2016-10-17 | PR-Z3-UT-PW-140-0020 | 98d | 0d |  |  | OK | 1.2.7.30 | PROC | PROC |
| PR-Z3-UT-PW-140-0040 |  | Technical Evaluation - Flanged Gate Valves |  | 8d | 2016-10-17 | 2016-10-26 | PR-Z3-UT-PW-140-0030 | 98d | 0d |  |  | OK | 1.2.7.30 | PROC | PROC |
| PR-Z3-UT-PW-140-0050 |  | PO - Flanged Gate Valves |  | 11.2d | 2016-10-26 | 2016-11-08 | PR-Z3-UT-PW-140-0040 | 98d | 0d |  |  | OK | 1.2.7.30 | PROC | PROC |
| PR-Z3-UT-PW-140-0060 |  | NMR 601 - Flanged Gate Valves |  | 12d | 2016-11-08 | 2016-11-22 | PR-Z3-UT-PW-140-0050 | 98d | 0d |  |  | OK | 1.2.7.30 | PROC | PROC |
| PR-Z3-UT-PW-140-0070 |  | NMR 602 - Flanged Gate Valves |  | 12d | 2016-11-22 | 2016-12-06 | PR-Z3-UT-PW-140-0060 | 98d | 0d |  |  | OK | 1.2.7.30 | PROC | PROC |
| PR-Z3-UT-PW-140-0080 |  | Start of Material Delivery - Flanged Gate Valves | milestone | 0d | 2017-01-21 | 2017-01-21 | PR-Z3-UT-PW-140-0070 FS+38.4d | 98d | 0d |  |  | OK | 1.2.7.30 | PROC | PROC |
| PR-Z3-UT-PW-140-0090 |  | Complete Material Delivery - Flanged Gate Valves |  | 12d | 2017-01-21 | 2017-02-02 | PR-Z3-UT-PW-140-0080 | 257.8d | 0d | Gate Valves, Butterfly Valves, Drain Valves, Air Release Valves [4 ea] | 10,627.28 | OK | 1.2.7.30 | PROC | PROC |
| PR-Z3-UT-PW-140-0100 |  | NMR 603 - Flanged Gate Valves |  | 4.8d | 2017-03-20 | 2017-03-26 | PR-Z3-UT-PW-140-0090 FS+38.4d | 257.8d | 175.6d |  |  | OK | 1.2.7.30 | PROC | PROC |

Notes:
- PR-Z3-UT-PW-138-0090: Expenses: (New Expense Item) 1407336
- PR-Z3-UT-PW-139-0090: Expenses: (New Expense Item) 51177.2
- PR-Z3-UT-PW-140-0090: Expenses: (New Expense Item) 10627.3

| ID | WBS | Activity | Type | Duration | Start | Finish | Predecessors | Total float | Free float | Resources | Cost | Wajid | RPI_P2 - BOQ ITEMS | RPI_P2 - PROCUREMENT | RPI_P2 - PHASE |
| --- | --- | --- | --- | --- | --- | --- | --- | --- | --- | --- | --- | --- | --- | --- | --- |
|  | 4 | **CS Pipe Sleeves & DI Fittings for Valve Boxes** |  |  | 2016-08-21 | 2017-01-25 |  |  |  |  |  |  |  |  |  |
| PR-Z3-UT-PW-141-0010 |  | RFQ - CS Pipe Sleeves & DI Fittings for Valve Boxes |  | 18d | 2016-08-21 | 2016-09-15 | PROC-GE-GE-GE-0010 FS+10.4d | 113.6d | 0d |  |  | OK | 1.2.7.30 | PROC | PROC |
| PR-Z3-UT-PW-141-0020 |  | Material Submittal - CS Pipe Sleeves & DI Fittings for Valve Boxes |  | 8d | 2016-09-15 | 2016-09-25 | PR-Z3-UT-PW-141-0010 | 113.6d | 0d |  |  | OK | 1.2.7.30 | PROC | PROC |
| PR-Z3-UT-PW-141-0030 |  | Material Approval - CS Pipe Sleeves & DI Fittings for Valve Boxes |  | 11.2d | 2016-09-25 | 2016-10-08 | PR-Z3-UT-PW-141-0020 | 113.6d | 0d |  |  | OK | 1.2.7.30 | PROC | PROC |
| PR-Z3-UT-PW-141-0040 |  | Technical Evaluation - CS Pipe Sleeves & DI Fittings for Valve Boxes |  | 8d | 2016-10-08 | 2016-10-17 | PR-Z3-UT-PW-141-0030 | 113.6d | 0d |  |  | OK | 1.2.7.30 | PROC | PROC |
| PR-Z3-UT-PW-141-0050 |  | PO - CS Pipe Sleeves & DI Fittings for Valve Boxes |  | 11.2d | 2016-10-17 | 2016-10-30 | PR-Z3-UT-PW-141-0040 | 113.6d | 0d |  |  | OK | 1.2.7.30 | PROC | PROC |
| PR-Z3-UT-PW-141-0060 |  | NMR 601 - CS Pipe Sleeves & DI Fittings for Valve Boxes |  | 12d | 2016-10-31 | 2016-11-13 | PR-Z3-UT-PW-141-0050 | 113.6d | 0d |  |  | OK | 1.2.7.30 | PROC | PROC |
| PR-Z3-UT-PW-141-0070 |  | NMR 602 - CS Pipe Sleeves & DI Fittings for Valve Boxes |  | 12d | 2016-11-14 | 2016-11-27 | PR-Z3-UT-PW-141-0060 | 113.6d | 0d |  |  | OK | 1.2.7.30 | PROC | PROC |
| PR-Z3-UT-PW-141-0080 |  | Start of Material Delivery - CS Pipe Sleeves & DI Fittings for Valve Boxes | milestone | 0d | 2017-01-02 | 2017-01-02 | PR-Z3-UT-PW-141-0070 FS+30.4d | 113.6d | 0d |  |  | OK | 1.2.7.30 | PROC | PROC |
| PR-Z3-UT-PW-141-0090 |  | Complete Material Delivery - CS Pipe Sleeves & DI Fittings for Valve Boxes |  | 12d | 2017-01-02 | 2017-01-16 | PR-Z3-UT-PW-141-0080 | 308.6d | 0d | CS Pipe Sleeves & DI Fittings for Valve Boxes [59 ea] | 131,438.17 | OK | 1.2.7.30 | PROC | PROC |
| PR-Z3-UT-PW-141-0100 |  | NMR 603 - CS Pipe Sleeves & DI Fittings for Valve Boxes |  | 8d | 2017-01-16 | 2017-01-25 | PR-Z3-UT-PW-141-0090 | 308.6d | 226.4d |  |  | OK | 1.2.7.30 | PROC | PROC |
|  | 5 | **Non-Metalic Inscet Screen 150 mm dia.** |  |  | 2016-08-30 | 2017-02-11 |  |  |  |  |  |  |  |  |  |
| PR-Z3-UT-PW-142-0010 |  | RFQ - Non-Metalic Inscet Screen 150 mm dia. |  | 18d | 2016-08-30 | 2016-09-25 | PROC-GE-GE-GE-0010 FS+18.4d | 294.2d | 0d |  |  | OK | 1.2.7.30 | PROC | PROC |
| PR-Z3-UT-PW-142-0020 |  | Material Submittal - Non-Metalic Inscet Screen 150 mm dia. |  | 8d | 2016-09-25 | 2016-10-04 | PR-Z3-UT-PW-142-0010 | 294.2d | 0d |  |  | OK | 1.2.7.30 | PROC | PROC |
| PR-Z3-UT-PW-142-0030 |  | Material Approval - Non-Metalic Inscet Screen 150 mm dia. |  | 11.2d | 2016-10-04 | 2016-10-17 | PR-Z3-UT-PW-142-0020 | 294.2d | 0d |  |  | OK | 1.2.7.30 | PROC | PROC |
| PR-Z3-UT-PW-142-0040 |  | Technical Evaluation - Non-Metalic Inscet Screen 150 mm dia. |  | 8d | 2016-10-17 | 2016-10-26 | PR-Z3-UT-PW-142-0030 | 294.2d | 0d |  |  | OK | 1.2.7.30 | PROC | PROC |
| PR-Z3-UT-PW-142-0050 |  | PO - Non-Metalic Inscet Screen 150 mm dia. |  | 11.2d | 2016-10-26 | 2016-11-08 | PR-Z3-UT-PW-142-0040 | 294.2d | 0d |  |  | OK | 1.2.7.30 | PROC | PROC |
| PR-Z3-UT-PW-142-0060 |  | NMR 601 - Non-Metalic Inscet Screen 150 mm dia. |  | 12d | 2016-11-09 | 2016-11-22 | PR-Z3-UT-PW-142-0050 | 294.2d | 0d |  |  | OK | 1.2.7.30 | PROC | PROC |
| PR-Z3-UT-PW-142-0070 |  | NMR 602 - Non-Metalic Inscet Screen 150 mm dia. |  | 12d | 2016-11-23 | 2016-12-06 | PR-Z3-UT-PW-142-0060 | 294.2d | 0d |  |  | OK | 1.2.7.30 | PROC | PROC |
| PR-Z3-UT-PW-142-0080 |  | Start of Material Delivery - Non-Metalic Inscet Screen 150 mm dia. | milestone | 0d | 2017-01-18 | 2017-01-18 | PR-Z3-UT-PW-142-0070 FS+36.8d | 294.2d | 0d |  |  | OK | 1.2.7.30 | PROC | PROC |
| PR-Z3-UT-PW-142-0090 |  | Complete Material Delivery - Non-Metalic Inscet Screen 150 mm dia. |  | 12d | 2017-01-18 | 2017-02-01 | PR-Z3-UT-PW-142-0080 | 294.2d | 0d | Non-Metalic Inscet Screen 150 mm dia. [7 ea] | 24,796.98 | OK | 1.2.7.30 | PROC | PROC |
| PR-Z3-UT-PW-142-0100 |  | NMR 603 - Non-Metalic Inscet Screen 150 mm dia. |  | 8d | 2017-02-01 | 2017-02-11 | PR-Z3-UT-PW-142-0090 | 294.2d | 212d |  |  | OK | 1.2.7.30 | PROC | PROC |
|  | 4 | **Irrigation System and related Material** |  |  | 2016-08-25 | 2017-04-08 |  |  |  |  |  |  |  |  |  |
|  | 1 | **UPVC Pipes & Fittings** |  |  | 2016-08-25 | 2017-04-08 |  |  |  |  |  |  |  |  |  |
| PR-Z3-UT-PW-143-0010 |  | RFQ - UPVC Pipes & Fittings |  | 18d | 2016-08-25 | 2016-09-20 | PROC-GE-GE-GE-0010 FS+14.4d | 211.6d | 0d |  |  | OK | 1.2.7.40 | PROC | PROC |
| PR-Z3-UT-PW-143-0020 |  | Material Submittal - UPVC Pipes & Fittings |  | 8d | 2016-09-20 | 2016-09-29 | PR-Z3-UT-PW-143-0010 | 211.6d | 0d |  |  | OK | 1.2.7.40 | PROC | PROC |
| PR-Z3-UT-PW-143-0030 |  | Material Approval - UPVC Pipes & Fittings |  | 11.2d | 2016-09-29 | 2016-10-12 | PR-Z3-UT-PW-143-0020 | 211.6d | 0d |  |  | OK | 1.2.7.40 | PROC | PROC |
| PR-Z3-UT-PW-143-0040 |  | Technical Evaluation - UPVC Pipes & Fittings |  | 8d | 2016-10-12 | 2016-10-22 | PR-Z3-UT-PW-143-0030 | 211.6d | 0d |  |  | OK | 1.2.7.40 | PROC | PROC |
| PR-Z3-UT-PW-143-0050 |  | PO - UPVC Pipes & Fittings |  | 11.2d | 2016-10-22 | 2016-11-03 | PR-Z3-UT-PW-143-0040 | 211.6d | 0d |  |  | OK | 1.2.7.40 | PROC | PROC |
| PR-Z3-UT-PW-143-0060 |  | NMR 601 - UPVC Pipes & Fittings |  | 12d | 2016-11-05 | 2016-11-17 | PR-Z3-UT-PW-143-0050 | 211.6d | 0d |  |  | OK | 1.2.7.40 | PROC | PROC |
| PR-Z3-UT-PW-143-0070 |  | NMR 602 - UPVC Pipes & Fittings |  | 12d | 2016-11-19 | 2016-12-01 | PR-Z3-UT-PW-143-0060 | 211.6d | 0d |  |  | OK | 1.2.7.40 | PROC | PROC |
| PR-Z3-UT-PW-143-0080 |  | Start of Material Delivery - UPVC Pipes & Fittings | milestone | 0d | 2017-01-04 | 2017-01-04 | PR-Z3-UT-PW-143-0070 FS+28.8d | 211.6d | 0d |  |  | OK | 1.2.7.40 | PROC | PROC |
| PR-Z3-UT-PW-143-0090 |  | Complete Material Delivery - UPVC Pipes & Fittings |  | 72d | 2017-01-04 | 2017-03-29 | PR-Z3-UT-PW-143-0080 | 246.2d | 0d | UPVC Pipes & Fittings including Blind Flanges [3014 Lm] | 447,335.88 | OK | 1.2.7.40 | PROC | PROC |
| PR-Z3-UT-PW-143-0100 |  | NMR 603 - UPVC Pipes & Fittings |  | 8d | 2017-03-29 | 2017-04-08 | PR-Z3-UT-PW-143-0090 | 246.2d | 164d |  |  | OK | 1.2.7.40 | PROC | PROC |

Notes:
- PR-Z3-UT-PW-141-0090: Expenses: (New Expense Item) 131438
- PR-Z3-UT-PW-142-0090: Expenses: (New Expense Item) 24797
- PR-Z3-UT-PW-143-0090: Expenses: (New Expense Item) 447336

| ID | WBS | Activity | Type | Duration | Start | Finish | Predecessors | Total float | Free float | Resources | Cost | Wajid | RPI_P2 - BOQ ITEMS | RPI_P2 - PROCUREMENT | RPI_P2 - PHASE |
| --- | --- | --- | --- | --- | --- | --- | --- | --- | --- | --- | --- | --- | --- | --- | --- |
|  | 3 | **Direct Buried Valves & Gate Valves (200 mm dia.)** |  |  | 2016-08-25 | 2017-02-08 |  |  |  |  |  |  |  |  |  |
| PR-Z3-UT-PW-144-0010 |  | RFQ - Direct Buried Valves & Gate Valves (200 mm dia.) |  | 18d | 2016-08-25 | 2016-09-20 | PROC-GE-GE-GE-0010 FS+14.4d | 137.6d | 0d |  |  | OK | 1.2.7.40 | PROC | PROC |
| PR-Z3-UT-PW-144-0020 |  | Material Submittal - Direct Buried Valves & Gate Valves (200 mm dia.) |  | 8d | 2016-09-20 | 2016-09-29 | PR-Z3-UT-PW-144-0010 | 137.6d | 0d |  |  | OK | 1.2.7.40 | PROC | PROC |
| PR-Z3-UT-PW-144-0030 |  | Material Approval - Direct Buried Valves & Gate Valves (200 mm dia.) |  | 11.2d | 2016-09-29 | 2016-10-12 | PR-Z3-UT-PW-144-0020 | 137.6d | 0d |  |  | OK | 1.2.7.40 | PROC | PROC |
| PR-Z3-UT-PW-144-0040 |  | Technical Evaluation - Direct Buried Valves & Gate Valves (200 mm dia.) |  | 8d | 2016-10-12 | 2016-10-22 | PR-Z3-UT-PW-144-0030 | 137.6d | 0d |  |  | OK | 1.2.7.40 | PROC | PROC |
| PR-Z3-UT-PW-144-0050 |  | PO - Direct Buried Valves & Gate Valves (200 mm dia.) |  | 11.2d | 2016-10-22 | 2016-11-03 | PR-Z3-UT-PW-144-0040 | 137.6d | 0d |  |  | OK | 1.2.7.40 | PROC | PROC |
| PR-Z3-UT-PW-144-0060 |  | NMR 601 - Direct Buried Valves & Gate Valves (200 mm dia.) |  | 12d | 2016-11-05 | 2016-11-17 | PR-Z3-UT-PW-144-0050 | 137.6d | 0d |  |  | OK | 1.2.7.40 | PROC | PROC |
| PR-Z3-UT-PW-144-0070 |  | NMR 602 - Direct Buried Valves & Gate Valves (200 mm dia.) |  | 12d | 2016-11-19 | 2016-12-01 | PR-Z3-UT-PW-144-0060 | 137.6d | 0d |  |  | OK | 1.2.7.40 | PROC | PROC |
| PR-Z3-UT-PW-144-0080 |  | Start of Material Delivery - Direct Buried Valves & Gate Valves (200 mm dia.) | milestone | 0d | 2017-01-16 | 2017-01-16 | PR-Z3-UT-PW-144-0070 FS+38.4d | 137.6d | 0d |  |  | OK | 1.2.7.40 | PROC | PROC |
| PR-Z3-UT-PW-144-0090 |  | Complete Material Delivery - Direct Buried Valves & Gate Valves (200 mm dia.) |  | 12d | 2017-01-16 | 2017-01-30 | PR-Z3-UT-PW-144-0080 | 296.6d | 0d | Direct Buried Valves & Gate Valves (200 mm dia.) for Irrigation [69 ea] | 440,760.97 | OK | 1.2.7.40 | PROC | PROC |
| PR-Z3-UT-PW-144-0100 |  | NMR 603 - Direct Buried Valves & Gate Valves (200 mm dia.) |  | 8d | 2017-01-30 | 2017-02-08 | PR-Z3-UT-PW-144-0090 | 296.6d | 214.4d |  |  | OK | 1.2.7.40 | PROC | PROC |
|  | 4 | **Puddle Sleeves, Metal Supports, Nut & Bolts, Gaskets, DI Fittings** |  |  | 2016-09-18 | 2017-02-16 |  |  |  |  |  |  |  |  |  |
| PR-Z3-UT-PW-145-0010 |  | RFQ - Puddle Sleeves, Metal Supports, Nut & Bolts, Gaskets, DI Fittings |  | 18d | 2016-09-18 | 2016-10-09 | PROC-GE-GE-GE-0010 FS+30d | 289d | 0d |  |  | OK | 1.2.7.40 | PROC | PROC |
| PR-Z3-UT-PW-145-0020 |  | Material Submittal - Puddle Sleeves, Metal Supports, Nut & Bolts, Gaskets, DI Fittings |  | 8d | 2016-10-09 | 2016-10-18 | PR-Z3-UT-PW-145-0010 | 289d | 0d |  |  | OK | 1.2.7.40 | PROC | PROC |
| PR-Z3-UT-PW-145-0030 |  | Material Approval - Puddle Sleeves, Metal Supports, Nut & Bolts, Gaskets, DI Fittings |  | 11.2d | 2016-10-18 | 2016-10-31 | PR-Z3-UT-PW-145-0020 | 289d | 0d |  |  | OK | 1.2.7.40 | PROC | PROC |
| PR-Z3-UT-PW-145-0040 |  | Technical Evaluation - Puddle Sleeves, Metal Supports, Nut & Bolts, Gaskets, DI Fittings |  | 8d | 2016-10-31 | 2016-11-09 | PR-Z3-UT-PW-145-0030 | 289d | 0d |  |  | OK | 1.2.7.40 | PROC | PROC |
| PR-Z3-UT-PW-145-0050 |  | PO - Puddle Sleeves, Metal Supports, Nut & Bolts, Gaskets, DI Fittings |  | 11.2d | 2016-11-09 | 2016-11-22 | PR-Z3-UT-PW-145-0040 | 289d | 0d |  |  | OK | 1.2.7.40 | PROC | PROC |
| PR-Z3-UT-PW-145-0060 |  | NMR 601 - Puddle Sleeves, Metal Supports, Nut & Bolts, Gaskets, DI Fittings |  | 12d | 2016-11-22 | 2016-12-06 | PR-Z3-UT-PW-145-0050 | 289d | 0d |  |  | OK | 1.2.7.40 | PROC | PROC |
| PR-Z3-UT-PW-145-0070 |  | NMR 602 - Puddle Sleeves, Metal Supports, Nut & Bolts, Gaskets, DI Fittings |  | 12d | 2016-12-06 | 2016-12-20 | PR-Z3-UT-PW-145-0060 | 289d | 0d |  |  | OK | 1.2.7.40 | PROC | PROC |
| PR-Z3-UT-PW-145-0080 |  | Start of Material Delivery - Puddle Sleeves, Metal Supports, Nut & Bolts, Gaskets, DI Fittings | milestone | 0d | 2017-01-25 | 2017-01-25 | PR-Z3-UT-PW-145-0070 FS+30.4d | 289d | 0d |  |  | OK | 1.2.7.40 | PROC | PROC |
| PR-Z3-UT-PW-145-0090 |  | Complete Material Delivery - Puddle Sleeves, Metal Supports, Nut & Bolts, Gaskets, DI Fittings |  | 12d | 2017-01-25 | 2017-02-07 | PR-Z3-UT-PW-145-0080 | 289d | 0d | DI Flanged Short Pipes, DI Tee, Puddle Sleeves, Nuts & Bolts, Gasket [309 ea] | 366,503.04 | OK | 1.2.7.40 | PROC | PROC |
| PR-Z3-UT-PW-145-0100 |  | NMR 603 - Puddle Sleeves, Metal Supports, Nut & Bolts, Gaskets, DI Fittings |  | 8d | 2017-02-08 | 2017-02-16 | PR-Z3-UT-PW-145-0090 | 289d | 206.8d |  |  | OK | 1.2.7.40 | PROC | PROC |
|  | 5 | **Dismantling Joints 200 mm dia.** |  |  | 2016-09-18 | 2017-02-16 |  |  |  |  |  |  |  |  |  |
| PR-Z3-UT-PW-146-0010 |  | RFQ - Dismantling Joints 200 mm dia. |  | 18d | 2016-09-18 | 2016-10-09 | PROC-GE-GE-GE-0010 FS+30d | 289d | 0d |  |  | OK | 1.2.7.40 | PROC | PROC |
| PR-Z3-UT-PW-146-0020 |  | Material Submittal - Dismantling Joints 200 mm dia. |  | 8d | 2016-10-09 | 2016-10-18 | PR-Z3-UT-PW-146-0010 | 289d | 0d |  |  | OK | 1.2.7.40 | PROC | PROC |
| PR-Z3-UT-PW-146-0030 |  | Material Approval - Dismantling Joints 200 mm dia. |  | 11.2d | 2016-10-18 | 2016-10-31 | PR-Z3-UT-PW-146-0020 | 289d | 0d |  |  | OK | 1.2.7.40 | PROC | PROC |
| PR-Z3-UT-PW-146-0040 |  | Technical Evaluation - Dismantling Joints 200 mm dia. |  | 8d | 2016-10-31 | 2016-11-09 | PR-Z3-UT-PW-146-0030 | 289d | 0d |  |  | OK | 1.2.7.40 | PROC | PROC |
| PR-Z3-UT-PW-146-0050 |  | PO - Dismantling Joints 200 mm dia. |  | 11.2d | 2016-11-09 | 2016-11-22 | PR-Z3-UT-PW-146-0040 | 289d | 0d |  |  | OK | 1.2.7.40 | PROC | PROC |
| PR-Z3-UT-PW-146-0060 |  | NMR 601 - Dismantling Joints 200 mm dia. |  | 12d | 2016-11-22 | 2016-12-06 | PR-Z3-UT-PW-146-0050 | 289d | 0d |  |  | OK | 1.2.7.40 | PROC | PROC |
| PR-Z3-UT-PW-146-0070 |  | NMR 602 - Dismantling Joints 200 mm dia. |  | 12d | 2016-12-06 | 2016-12-20 | PR-Z3-UT-PW-146-0060 | 289d | 0d |  |  | OK | 1.2.7.40 | PROC | PROC |
| PR-Z3-UT-PW-146-0080 |  | Start of Material Delivery - Dismantling Joints 200 mm dia. | milestone | 0d | 2017-01-25 | 2017-01-25 | PR-Z3-UT-PW-146-0070 FS+30.4d | 289d | 0d |  |  | OK | 1.2.7.40 | PROC | PROC |
| PR-Z3-UT-PW-146-0090 |  | Complete Material Delivery - Dismantling Joints 200 mm dia. |  | 12d | 2017-01-25 | 2017-02-07 | PR-Z3-UT-PW-146-0080 | 289d | 0d | Dismantling Joints - Valve Box Fittings [44 ea] | 337,090.58 | OK | 1.2.7.40 | PROC | PROC |
| PR-Z3-UT-PW-146-0100 |  | NMR 603 - Dismantling Joints 200 mm dia. |  | 8d | 2017-02-08 | 2017-02-16 | PR-Z3-UT-PW-146-0090 | 289d | 206.8d |  |  | OK | 1.2.7.40 | PROC | PROC |

Notes:
- PR-Z3-UT-PW-144-0090: Expenses: (New Expense Item) 440761
- PR-Z3-UT-PW-145-0090: Expenses: (New Expense Item) 366503
- PR-Z3-UT-PW-146-0090: Expenses: (New Expense Item) 337091

| ID | WBS | Activity | Type | Duration | Start | Finish | Predecessors | Total float | Free float | Resources | Cost | Wajid | RPI_P2 - BOQ ITEMS | RPI_P2 - PROCUREMENT | RPI_P2 - PHASE |
| --- | --- | --- | --- | --- | --- | --- | --- | --- | --- | --- | --- | --- | --- | --- | --- |
|  | 8 | **Warning Tapes** |  |  | 2016-08-27 | 2017-02-19 |  |  |  |  |  |  |  |  |  |
| PR-Z3-UT-PW-147-0010 |  | RFQ - Warning Tapes |  | 12d | 2016-08-27 | 2016-09-10 | PROC-GE-GE-GE-0010 FS+15.2d | 119.4d | 0d |  |  | OK | 1.2.7.40 | PROC | PROC |
| PR-Z3-UT-PW-147-0020 |  | Material Submittal - Warning Tapes |  | 8d | 2016-09-10 | 2016-09-24 | PR-Z3-UT-PW-147-0010 | 119.4d | 0d |  |  | OK | 1.2.7.40 | PROC | PROC |
| PR-Z3-UT-PW-147-0030 |  | Material Approval - Warning Tapes |  | 11.2d | 2016-09-24 | 2016-10-06 | PR-Z3-UT-PW-147-0020 | 119.4d | 0d |  |  | OK | 1.2.7.40 | PROC | PROC |
| PR-Z3-UT-PW-147-0040 |  | Technical Evaluation - Warning Tapes |  | 8d | 2016-10-06 | 2016-10-16 | PR-Z3-UT-PW-147-0030 | 119.4d | 0d |  |  | OK | 1.2.7.40 | PROC | PROC |
| PR-Z3-UT-PW-147-0050 |  | PO - Warning Tapes |  | 11.2d | 2016-10-16 | 2016-10-29 | PR-Z3-UT-PW-147-0040 | 119.4d | 0d |  |  | OK | 1.2.7.40 | PROC | PROC |
| PR-Z3-UT-PW-147-0060 |  | NMR 601 - Warning Tapes |  | 12d | 2016-10-29 | 2016-11-12 | PR-Z3-UT-PW-147-0050 | 119.4d | 0d |  |  | OK | 1.2.7.40 | PROC | PROC |
| PR-Z3-UT-PW-147-0070 |  | NMR 602 - Warning Tapes |  | 12d | 2016-11-12 | 2016-11-26 | PR-Z3-UT-PW-147-0060 | 119.4d | 0d |  |  | OK | 1.2.7.40 | PROC | PROC |
| PR-Z3-UT-PW-147-0080 |  | Start of Material Delivery - Warning Tapes | milestone | 0d | 2016-12-01 | 2016-12-01 | PR-Z3-UT-PW-147-0070 FS+4.8d | 119.4d | 0d |  |  | OK | 1.2.7.40 | PROC | PROC |
| PR-Z3-UT-PW-147-0090 |  | Complete Material Delivery - Warning Tapes |  | 60d | 2016-12-01 | 2017-02-09 | PR-Z3-UT-PW-147-0080 | 287.4d | 0d | Warning Tapes [7710 Lm] | 27,362.31 | OK | 1.2.7.40 | PROC | PROC |
| PR-Z3-UT-PW-147-0100 |  | NMR 603 - Warning Tapes |  | 8d | 2017-02-09 | 2017-02-19 | PR-Z3-UT-PW-147-0090 | 287.4d | 205.2d |  |  | OK | 1.2.7.40 | PROC | PROC |
|  | 9 | **Sand for Backfilling** |  |  | 2016-08-30 | 2017-02-02 |  |  |  |  |  |  |  |  |  |
| PR-Z3-UT-PW-148-0010 |  | RFQ - Sand for Backfilling |  | 12d | 2016-08-30 | 2016-09-18 | PROC-GE-GE-GE-0010 FS+18d | 301.4d | 0d |  |  | OK | 1.2.7.40 | PROC | PROC |
| PR-Z3-UT-PW-148-0020 |  | Material Submittal - Sand for Backfilling |  | 8d | 2016-09-18 | 2016-09-27 | PR-Z3-UT-PW-148-0010 | 301.4d | 0d |  |  | OK | 1.2.7.40 | PROC | PROC |
| PR-Z3-UT-PW-148-0030 |  | Material Approval - Sand for Backfilling |  | 11.2d | 2016-09-27 | 2016-10-10 | PR-Z3-UT-PW-148-0020 | 301.4d | 0d |  |  | OK | 1.2.7.40 | PROC | PROC |
| PR-Z3-UT-PW-148-0040 |  | Technical Evaluation - Sand for Backfilling |  | 8d | 2016-10-10 | 2016-10-19 | PR-Z3-UT-PW-148-0030 | 301.4d | 0d |  |  | OK | 1.2.7.40 | PROC | PROC |
| PR-Z3-UT-PW-148-0050 |  | PO - Sand for Backfilling |  | 11.2d | 2016-10-19 | 2016-11-01 | PR-Z3-UT-PW-148-0040 | 301.4d | 0d |  |  | OK | 1.2.7.40 | PROC | PROC |
| PR-Z3-UT-PW-148-0060 |  | NMR 601 - Sand for Backfilling |  | 4.8d | 2016-11-01 | 2016-11-07 | PR-Z3-UT-PW-148-0050 | 301.4d | 0d |  |  | OK | 1.2.7.40 | PROC | PROC |
| PR-Z3-UT-PW-148-0070 |  | NMR 602 - Sand for Backfilling |  | 4.8d | 2016-11-07 | 2016-11-13 | PR-Z3-UT-PW-148-0060 | 301.4d | 0d |  |  | OK | 1.2.7.40 | PROC | PROC |
| PR-Z3-UT-PW-148-0080 |  | Start of Material Delivery - Sand for Backfilling | milestone | 0d | 2016-11-15 | 2016-11-15 | PR-Z3-UT-PW-148-0070 FS+2.4d | 301.4d | 0d |  |  | OK | 1.2.7.40 | PROC | PROC |
| PR-Z3-UT-PW-148-0090 |  | Complete Material Delivery - Sand for Backfilling |  | 60d | 2016-11-15 | 2017-01-24 | PR-Z3-UT-PW-148-0080 | 301.4d | 0d | Sand for Backfilling [462.62 Cum] | 31,521.38 | OK | 1.2.7.40 | PROC | PROC |
| PR-Z3-UT-PW-148-0100 |  | NMR 603 - Sand for Backfilling |  | 8d | 2017-01-24 | 2017-02-02 | PR-Z3-UT-PW-148-0090 | 301.4d | 219.2d |  |  | OK | 1.2.7.40 | PROC | PROC |
|  | 10 | **Red Tile for Irrigation Cables** |  |  | 2016-08-27 | 2017-02-09 |  |  |  |  |  |  |  |  |  |
| PR-Z3-UT-PW-149-0010 |  | RFQ - Red Tile for Irrigation Cables |  | 18d | 2016-08-27 | 2016-09-21 | PROC-GE-GE-GE-0010 FS+15.2d | 295.8d | 0d |  |  | OK | 1.2.7.40 | PROC | PROC |
| PR-Z3-UT-PW-149-0020 |  | Material Submittal - Red Tile for Irrigation Cables |  | 8d | 2016-09-21 | 2016-10-01 | PR-Z3-UT-PW-149-0010 | 295.8d | 0d |  |  | OK | 1.2.7.40 | PROC | PROC |
| PR-Z3-UT-PW-149-0030 |  | Material Approval - Red Tile for Irrigation Cables |  | 11.2d | 2016-10-01 | 2016-10-13 | PR-Z3-UT-PW-149-0020 | 295.8d | 0d |  |  | OK | 1.2.7.40 | PROC | PROC |
| PR-Z3-UT-PW-149-0040 |  | Technical Evaluation - Red Tile for Irrigation Cables |  | 8d | 2016-10-13 | 2016-10-23 | PR-Z3-UT-PW-149-0030 | 295.8d | 0d |  |  | OK | 1.2.7.40 | PROC | PROC |
| PR-Z3-UT-PW-149-0050 |  | PO - Red Tile for Irrigation Cables |  | 11.2d | 2016-10-23 | 2016-11-05 | PR-Z3-UT-PW-149-0040 | 295.8d | 0d |  |  | OK | 1.2.7.40 | PROC | PROC |
| PR-Z3-UT-PW-149-0060 |  | NMR 601 - Red Tile for Irrigation Cables |  | 4.8d | 2016-11-05 | 2016-11-10 | PR-Z3-UT-PW-149-0050 | 295.8d | 0d |  |  | OK | 1.2.7.40 | PROC | PROC |
| PR-Z3-UT-PW-149-0070 |  | NMR 602 - Red Tile for Irrigation Cables |  | 4.8d | 2016-11-10 | 2016-11-16 | PR-Z3-UT-PW-149-0060 | 295.8d | 0d |  |  | OK | 1.2.7.40 | PROC | PROC |
| PR-Z3-UT-PW-149-0080 |  | Start of Material Delivery - Red Tile for Irrigation Cables | milestone | 0d | 2016-11-22 | 2016-11-22 | PR-Z3-UT-PW-149-0070 FS+4.8d | 295.8d | 0d |  |  | OK | 1.2.7.40 | PROC | PROC |
| PR-Z3-UT-PW-149-0090 |  | Complete Material Delivery - Red Tile for Irrigation Cables |  | 60d | 2016-11-22 | 2017-01-31 | PR-Z3-UT-PW-149-0080 | 295.8d | 0d | Red Tiles [19275.8 ea] | 82,086.94 | OK | 1.2.7.40 | PROC | PROC |
| PR-Z3-UT-PW-149-0100 |  | NMR 603 - Red Tile for Irrigation Cables |  | 8d | 2017-01-31 | 2017-02-09 | PR-Z3-UT-PW-149-0090 | 295.8d | 213.6d |  |  | OK | 1.2.7.40 | PROC | PROC |

Notes:
- PR-Z3-UT-PW-147-0090: Expenses: (New Expense Item) 27362.3
- PR-Z3-UT-PW-148-0090: Expenses: (New Expense Item) 31521.4
- PR-Z3-UT-PW-149-0090: Expenses: (New Expense Item) 82086.9

| ID | WBS | Activity | Type | Duration | Start | Finish | Predecessors | Total float | Free float | Resources | Cost | Wajid | RPI_P2 - BOQ ITEMS | RPI_P2 - PROCUREMENT | RPI_P2 - PHASE |
| --- | --- | --- | --- | --- | --- | --- | --- | --- | --- | --- | --- | --- | --- | --- | --- |
|  | 11 | **3/4" Rigid PVC Conduits** |  |  | 2016-11-06 | 2017-03-02 |  |  |  |  |  |  |  |  |  |
| PR-Z3-UT-PW-150-0010 |  | RFQ - 3/4" Rigid PVC Conduits |  | 18d | 2016-11-06 | 2016-11-27 | PROC-GE-GE-GE-0010 FS+72d | 277.4d | 0d |  |  | OK | 1.2.7.40 | PROC | PROC |
| PR-Z3-UT-PW-150-0020 |  | Material Submittal - 3/4" Rigid PVC Conduits |  | 8d | 2016-11-27 | 2016-12-06 | PR-Z3-UT-PW-150-0010 | 277.4d | 0d |  |  | OK | 1.2.7.40 | PROC | PROC |
| PR-Z3-UT-PW-150-0030 |  | Material Approval - 3/4" Rigid PVC Conduits |  | 11.2d | 2016-12-06 | 2016-12-19 | PR-Z3-UT-PW-150-0020 | 277.4d | 0d |  |  | OK | 1.2.7.40 | PROC | PROC |
| PR-Z3-UT-PW-150-0040 |  | Technical Evaluation - 3/4" Rigid PVC Conduits |  | 8d | 2016-12-19 | 2016-12-28 | PR-Z3-UT-PW-150-0030 | 277.4d | 0d |  |  | OK | 1.2.7.40 | PROC | PROC |
| PR-Z3-UT-PW-150-0050 |  | PO - 3/4" Rigid PVC Conduits |  | 11.2d | 2016-12-28 | 2017-01-10 | PR-Z3-UT-PW-150-0040 | 277.4d | 0d |  |  | OK | 1.2.7.40 | PROC | PROC |
| PR-Z3-UT-PW-150-0060 |  | NMR 601 - 3/4" Rigid PVC Conduits |  | 12d | 2017-01-10 | 2017-01-24 | PR-Z3-UT-PW-150-0050 | 277.4d | 0d |  |  | OK | 1.2.7.40 | PROC | PROC |
| PR-Z3-UT-PW-150-0070 |  | NMR 602 - 3/4" Rigid PVC Conduits |  | 12d | 2017-01-24 | 2017-02-07 | PR-Z3-UT-PW-150-0060 | 277.4d | 0d |  |  | OK | 1.2.7.40 | PROC | PROC |
| PR-Z3-UT-PW-150-0080 |  | Start of Material Delivery - 3/4" Rigid PVC Conduits | milestone | 0d | 2017-02-07 | 2017-02-07 | PR-Z3-UT-PW-150-0070 | 277.4d | 0d |  |  | OK | 1.2.7.40 | PROC | PROC |
| PR-Z3-UT-PW-150-0090 |  | Complete Material Delivery - 3/4" Rigid PVC Conduits |  | 12d | 2017-02-07 | 2017-02-21 | PR-Z3-UT-PW-150-0080 | 277.4d | 0d | 3/4" Rigid Conduits PVC Coated [79 Lm] | 2,803.55 | OK | 1.2.7.40 | PROC | PROC |
| PR-Z3-UT-PW-150-0100 |  | NMR 603 - 3/4" Rigid PVC Conduits |  | 8d | 2017-02-21 | 2017-03-02 | PR-Z3-UT-PW-150-0090 | 277.4d | 195.2d |  |  | OK | 1.2.7.40 | PROC | PROC |
|  | 2 | **Direct Buried Irrigation Wires** |  |  | 2016-09-07 | 2017-02-27 |  |  |  |  |  |  |  |  |  |
| PR-Z3-UT-PW-151-0010 |  | RFQ - Direct Burried Irrigation Wires |  | 18d | 2016-09-07 | 2016-10-03 | PROC-GE-GE-GE-0010 FS+25d | 179.8d | 0d |  |  | OK | 1.2.7.40 | PROC | PROC |
| PR-Z3-UT-PW-151-0020 |  | Material Submittal - Direct Burried Irrigation Wires |  | 8d | 2016-10-03 | 2016-10-12 | PR-Z3-UT-PW-151-0010 | 179.8d | 0d |  |  | OK | 1.2.7.40 | PROC | PROC |
| PR-Z3-UT-PW-151-0030 |  | Material Approval - Direct Burried Irrigation Wires |  | 11.2d | 2016-10-12 | 2016-10-25 | PR-Z3-UT-PW-151-0020 | 179.8d | 0d |  |  | OK | 1.2.7.40 | PROC | PROC |
| PR-Z3-UT-PW-151-0040 |  | Technical Evaluation - Direct Burried Irrigation Wires |  | 8d | 2016-10-25 | 2016-11-03 | PR-Z3-UT-PW-151-0030 | 179.8d | 0d |  |  | OK | 1.2.7.40 | PROC | PROC |
| PR-Z3-UT-PW-151-0050 |  | PO - Direct Burried Irrigation Wires |  | 11.2d | 2016-11-03 | 2016-11-16 | PR-Z3-UT-PW-151-0040 | 179.8d | 0d |  |  | OK | 1.2.7.40 | PROC | PROC |
| PR-Z3-UT-PW-151-0060 |  | NMR 601 - Direct Burried Irrigation Wires |  | 12d | 2016-11-16 | 2016-11-30 | PR-Z3-UT-PW-151-0050 | 179.8d | 0d |  |  | OK | 1.2.7.40 | PROC | PROC |
| PR-Z3-UT-PW-151-0070 |  | NMR 602 - Direct Burried Irrigation Wires |  | 12d | 2016-11-30 | 2016-12-14 | PR-Z3-UT-PW-151-0060 | 179.8d | 0d |  |  | OK | 1.2.7.40 | PROC | PROC |
| PR-Z3-UT-PW-151-0080 |  | Start of Material Delivery - Direct Burried Irrigation Wires | milestone | 0d | 2017-01-28 | 2017-01-28 | PR-Z3-UT-PW-151-0070 FS+37.6d | 179.8d | 0d |  |  | OK | 1.2.7.40 | PROC | PROC |
| PR-Z3-UT-PW-151-0090 |  | Complete Material Delivery - Direct Burried Irrigation Wires |  | 18d | 2017-01-28 | 2017-02-18 | PR-Z3-UT-PW-151-0080 | 280.8d | 0d | Direct Buried Irrigation Wires [5706 Lm] | 40,498.91 | OK | 1.2.7.40 | PROC | PROC |
| PR-Z3-UT-PW-151-0100 |  | NMR 603 - Direct Burried Irrigation Wires |  | 8d | 2017-02-18 | 2017-02-27 | PR-Z3-UT-PW-151-0090 | 280.8d | 198.6d |  |  | OK | 1.2.7.40 | PROC | PROC |
|  | 5 | **Lighting Network System and related Material** |  |  | 2016-08-23 | 2017-04-09 |  |  |  |  |  |  |  |  |  |
|  | 1 | **Sand for Backfilling** |  |  | 2016-08-23 | 2017-01-22 |  |  |  |  |  |  |  |  |  |
| PR-Z3-UT-EL-152-0010 |  | RFQ - Sand for Backfilling |  | 18d | 2016-08-23 | 2016-09-18 | PROC-GE-GE-GE-0010 FS+12d | 311.8d | 0d |  |  | OK | 1.2.7.50 | PROC | PROC |
| PR-Z3-UT-EL-152-0020 |  | Material Submittal - Sand for Backfilling |  | 8d | 2016-09-18 | 2016-09-27 | PR-Z3-UT-EL-152-0010 | 311.8d | 0d |  |  | OK | 1.2.7.50 | PROC | PROC |
| PR-Z3-UT-EL-152-0030 |  | Material Approval - Sand for Backfilling |  | 11.2d | 2016-09-27 | 2016-10-10 | PR-Z3-UT-EL-152-0020 | 311.8d | 0d |  |  | OK | 1.2.7.50 | PROC | PROC |
| PR-Z3-UT-EL-152-0040 |  | Technical Evaluation - Sand for Backfilling |  | 8d | 2016-10-10 | 2016-10-19 | PR-Z3-UT-EL-152-0030 | 311.8d | 0d |  |  | OK | 1.2.7.50 | PROC | PROC |
| PR-Z3-UT-EL-152-0050 |  | PO - Sand for Backfilling |  | 11.2d | 2016-10-19 | 2016-11-01 | PR-Z3-UT-EL-152-0040 | 311.8d | 0d |  |  | OK | 1.2.7.50 | PROC | PROC |
| PR-Z3-UT-EL-152-0060 |  | NMR 601 - Sand for Backfilling |  | 4.8d | 2016-11-01 | 2016-11-07 | PR-Z3-UT-EL-152-0050 | 311.8d | 0d |  |  | OK | 1.2.7.50 | PROC | PROC |
| PR-Z3-UT-EL-152-0070 |  | NMR 602 - Sand for Backfilling |  | 4.8d | 2016-11-07 | 2016-11-13 | PR-Z3-UT-EL-152-0060 | 311.8d | 0d |  |  | OK | 1.2.7.50 | PROC | PROC |
| PR-Z3-UT-EL-152-0080 |  | Start of Material Delivery - Sand for Backfilling | milestone | 0d | 2016-11-13 | 2016-11-13 | PR-Z3-UT-EL-152-0070 | 311.8d | 0d |  |  | OK | 1.2.7.50 | PROC | PROC |
| PR-Z3-UT-EL-152-0090 |  | Complete Material Delivery - Sand for Backfilling |  | 60d | 2016-11-13 | 2017-01-22 | PR-Z3-UT-EL-152-0080 | 311.8d | 229.6d | Sand for Backfilling [1325.64 Cum] | 90,602.3 | OK | 1.2.7.50 | PROC | PROC |

Notes:
- PR-Z3-UT-PW-150-0090: Expenses: (New Expense Item) 2803.55
- PR-Z3-UT-PW-151-0090: Expenses: (New Expense Item) 40498.9
- PR-Z3-UT-EL-152-0090: Expenses: (New Expense Item) 90602.3

| ID | WBS | Activity | Type | Duration | Start | Finish | Predecessors | Total float | Free float | Resources | Cost | Wajid | RPI_P2 - BOQ ITEMS | RPI_P2 - PROCUREMENT | RPI_P2 - PHASE |
| --- | --- | --- | --- | --- | --- | --- | --- | --- | --- | --- | --- | --- | --- | --- | --- |
|  | 2 | **Red Tiles** |  |  | 2016-08-27 | 2017-02-02 |  |  |  |  |  |  |  |  |  |
| PR-Z3-UT-EL-153-0010 |  | RFQ - Red Tiles |  | 12d | 2016-08-27 | 2016-09-10 | PROC-GE-GE-GE-0010 FS+15.2d | 301.8d | 0d |  |  | OK | 1.2.7.50 | PROC | PROC |
| PR-Z3-UT-EL-153-0020 |  | Material Submittal - Red Tiles |  | 8d | 2016-09-10 | 2016-09-24 | PR-Z3-UT-EL-153-0010 | 301.8d | 0d |  |  | OK | 1.2.7.50 | PROC | PROC |
| PR-Z3-UT-EL-153-0030 |  | Material Approval - Red Tiles |  | 11.2d | 2016-09-24 | 2016-10-06 | PR-Z3-UT-EL-153-0020 | 301.8d | 0d |  |  | OK | 1.2.7.50 | PROC | PROC |
| PR-Z3-UT-EL-153-0040 |  | Technical Evaluation - Red Tiles |  | 8d | 2016-10-06 | 2016-10-16 | PR-Z3-UT-EL-153-0030 | 301.8d | 0d |  |  | OK | 1.2.7.50 | PROC | PROC |
| PR-Z3-UT-EL-153-0050 |  | PO - Red Tiles |  | 11.2d | 2016-10-16 | 2016-10-29 | PR-Z3-UT-EL-153-0040 | 301.8d | 0d |  |  | OK | 1.2.7.50 | PROC | PROC |
| PR-Z3-UT-EL-153-0060 |  | NMR 601 - Red Tiles |  | 4.8d | 2016-10-29 | 2016-11-03 | PR-Z3-UT-EL-153-0050 | 301.8d | 0d |  |  | OK | 1.2.7.50 | PROC | PROC |
| PR-Z3-UT-EL-153-0070 |  | NMR 602 - Red Tiles |  | 4.8d | 2016-11-03 | 2016-11-09 | PR-Z3-UT-EL-153-0060 | 301.8d | 0d |  |  | OK | 1.2.7.50 | PROC | PROC |
| PR-Z3-UT-EL-153-0080 |  | Start of Material Delivery - Red Tiles | milestone | 0d | 2016-11-15 | 2016-11-15 | PR-Z3-UT-EL-153-0070 FS+4.8d | 301.8d | 0d |  |  | OK | 1.2.7.50 | PROC | PROC |
| PR-Z3-UT-EL-153-0090 |  | Complete Material Delivery - Red Tiles |  | 60d | 2016-11-15 | 2017-01-24 | PR-Z3-UT-EL-153-0080 | 301.8d | 0d | Red Tiles [14235 ea] | 50,672.21 | OK | 1.2.7.50 | PROC | PROC |
| PR-Z3-UT-EL-153-0100 |  | NMR 603 - Red Tiles |  | 8d | 2017-01-24 | 2017-02-02 | PR-Z3-UT-EL-153-0090 | 301.8d | 219.6d |  |  | OK | 1.2.7.50 | PROC | PROC |
|  | 3 | **Warning Tapes** |  |  | 2016-08-27 | 2017-02-02 |  |  |  |  |  |  |  |  |  |
| PR-Z3-UT-EL-154-0010 |  | RFQ - Warning Tapes |  | 12d | 2016-08-27 | 2016-09-10 | PROC-GE-GE-GE-0010 FS+15.2d | 301.8d | 0d |  |  | OK | 1.2.7.50 | PROC | PROC |
| PR-Z3-UT-EL-154-0020 |  | Material Submittal - Warning Tapes |  | 8d | 2016-09-10 | 2016-09-24 | PR-Z3-UT-EL-154-0010 | 301.8d | 0d |  |  | OK | 1.2.7.50 | PROC | PROC |
| PR-Z3-UT-EL-154-0030 |  | Material Approval - Warning Tapes |  | 11.2d | 2016-09-24 | 2016-10-06 | PR-Z3-UT-EL-154-0020 | 301.8d | 0d |  |  | OK | 1.2.7.50 | PROC | PROC |
| PR-Z3-UT-EL-154-0040 |  | Technical Evaluation - Warning Tapes |  | 8d | 2016-10-06 | 2016-10-16 | PR-Z3-UT-EL-154-0030 | 301.8d | 0d |  |  | OK | 1.2.7.50 | PROC | PROC |
| PR-Z3-UT-EL-154-0050 |  | PO - Warning Tapes |  | 11.2d | 2016-10-16 | 2016-10-29 | PR-Z3-UT-EL-154-0040 | 301.8d | 0d |  |  | OK | 1.2.7.50 | PROC | PROC |
| PR-Z3-UT-EL-154-0060 |  | NMR 601 - Warning Tapes |  | 4.8d | 2016-10-29 | 2016-11-03 | PR-Z3-UT-EL-154-0050 | 301.8d | 0d |  |  | OK | 1.2.7.50 | PROC | PROC |
| PR-Z3-UT-EL-154-0070 |  | NMR 602 - Warning Tapes |  | 4.8d | 2016-11-03 | 2016-11-09 | PR-Z3-UT-EL-154-0060 | 301.8d | 0d |  |  | OK | 1.2.7.50 | PROC | PROC |
| PR-Z3-UT-EL-154-0080 |  | Start of Material Delivery - Warning Tapes | milestone | 0d | 2016-11-15 | 2016-11-15 | PR-Z3-UT-EL-154-0070 FS+4.8d | 301.8d | 0d |  |  | OK | 1.2.7.50 | PROC | PROC |
| PR-Z3-UT-EL-154-0090 |  | Complete Material Delivery - Warning Tapes |  | 60d | 2016-11-15 | 2017-01-24 | PR-Z3-UT-EL-154-0080 | 301.8d | 0d | Warning Tapes [2847 Lm] | 10,134.44 | OK | 1.2.7.50 | PROC | PROC |
| PR-Z3-UT-EL-154-0100 |  | NMR 603 - Warning Tapes |  | 8d | 2017-01-24 | 2017-02-02 | PR-Z3-UT-EL-154-0090 | 301.8d | 219.6d |  |  | OK | 1.2.7.50 | PROC | PROC |
|  | 4 | **LV Cables** |  |  | 2016-10-05 | 2017-04-09 |  |  |  |  |  |  |  |  |  |
| PR-Z3-UT-EL-155-0010 |  | RFQ - LV Cables |  | 6d | 2016-10-05 | 2016-10-12 | PROC-GE-GE-GE-0010 FS+45d | 245.2d | 0d |  |  | OK | 1.2.7.50 | PROC | PROC |
| PR-Z3-UT-EL-155-0020 |  | Material Submittal - LV Cables |  | 8d | 2016-10-12 | 2016-10-22 | PR-Z3-UT-EL-155-0010 | 245.2d | 0d |  |  | OK | 1.2.7.50 | PROC | PROC |
| PR-Z3-UT-EL-155-0030 |  | Material Approval - LV Cables |  | 11.2d | 2016-10-22 | 2016-11-03 | PR-Z3-UT-EL-155-0020 | 245.2d | 0d |  |  | OK | 1.2.7.50 | PROC | PROC |
| PR-Z3-UT-EL-155-0040 |  | Technical Evaluation - LV Cables |  | 8d | 2016-11-03 | 2016-11-13 | PR-Z3-UT-EL-155-0030 | 245.2d | 0d |  |  | OK | 1.2.7.50 | PROC | PROC |
| PR-Z3-UT-EL-155-0050 |  | PO - LV Cables |  | 11.2d | 2016-11-13 | 2016-11-26 | PR-Z3-UT-EL-155-0040 | 245.2d | 0d |  |  | OK | 1.2.7.50 | PROC | PROC |
| PR-Z3-UT-EL-155-0060 |  | NMR 601 - LV Cables |  | 4.8d | 2016-11-26 | 2016-12-01 | PR-Z3-UT-EL-155-0050 | 245.2d | 0d |  |  | OK | 1.2.7.50 | PROC | PROC |
| PR-Z3-UT-EL-155-0070 |  | NMR 602 - LV Cables |  | 4.8d | 2016-12-01 | 2016-12-07 | PR-Z3-UT-EL-155-0060 | 245.2d | 0d |  |  | OK | 1.2.7.50 | PROC | PROC |
| PR-Z3-UT-EL-155-0080 |  | Start of Material Delivery - LV Cables | milestone | 0d | 2017-01-19 | 2017-01-19 | PR-Z3-UT-EL-155-0070 FS+37.6d | 245.2d | 0d |  |  | OK | 1.2.7.50 | PROC | PROC |
| PR-Z3-UT-EL-155-0090 |  | Complete Material Delivery - LV Cables |  | 60d | 2017-01-19 | 2017-03-30 | PR-Z3-UT-EL-155-0080 | 245.2d | 0d | LV Cables [28940 Lm] | 308,418.81 | OK | 1.2.7.50 | PROC | PROC |
| PR-Z3-UT-EL-155-0100 |  | NMR 603 - LV Cables |  | 8d | 2017-03-30 | 2017-04-09 | PR-Z3-UT-EL-155-0090 | 245.2d | 163d |  |  | OK | 1.2.7.50 | PROC | PROC |

Notes:
- PR-Z3-UT-EL-153-0090: Expenses: (New Expense Item) 50672.2
- PR-Z3-UT-EL-154-0090: Expenses: (New Expense Item) 10134.4
- PR-Z3-UT-EL-155-0090: Expenses: (New Expense Item) 308419

| ID | WBS | Activity | Type | Duration | Start | Finish | Predecessors | Total float | Free float | Resources | Cost | Wajid | RPI_P2 - BOQ ITEMS | RPI_P2 - PROCUREMENT | RPI_P2 - PHASE |
| --- | --- | --- | --- | --- | --- | --- | --- | --- | --- | --- | --- | --- | --- | --- | --- |
|  | 5 | **PVC Conduits (Walkway & Landscape Lights)** |  |  | 2016-10-23 | 2017-03-16 |  |  |  |  |  |  |  |  |  |
| PR-Z3-UT-EL-156-0010 |  | RFQ - PVC Conduits (Walkway & Landscape Lights) |  | 8d | 2016-10-23 | 2016-11-01 | PROC-GE-GE-GE-0010 FS+60d | 265.8d | 0d |  |  | OK | 1.2.7.50 | PROC | PROC |
| PR-Z3-UT-EL-156-0020 |  | Material Submittal - PVC Conduits (Walkway & Landscape Lights) |  | 8d | 2016-11-01 | 2016-11-10 | PR-Z3-UT-EL-156-0010 | 265.8d | 0d |  |  | OK | 1.2.7.50 | PROC | PROC |
| PR-Z3-UT-EL-156-0030 |  | Material Approval - PVC Conduits (Walkway & Landscape Lights) |  | 11.2d | 2016-11-10 | 2016-11-23 | PR-Z3-UT-EL-156-0020 | 265.8d | 0d |  |  | OK | 1.2.7.50 | PROC | PROC |
| PR-Z3-UT-EL-156-0040 |  | Technical Evaluation - PVC Conduits (Walkway & Landscape Lights) |  | 8d | 2016-11-23 | 2016-12-03 | PR-Z3-UT-EL-156-0030 | 265.8d | 0d |  |  | OK | 1.2.7.50 | PROC | PROC |
| PR-Z3-UT-EL-156-0050 |  | PO - PVC Conduits (Walkway & Landscape Lights) |  | 11.2d | 2016-12-03 | 2016-12-15 | PR-Z3-UT-EL-156-0040 | 265.8d | 0d |  |  | OK | 1.2.7.50 | PROC | PROC |
| PR-Z3-UT-EL-156-0060 |  | NMR 601 - PVC Conduits (Walkway & Landscape Lights) |  | 4.8d | 2016-12-15 | 2016-12-21 | PR-Z3-UT-EL-156-0050 | 265.8d | 0d |  |  | OK | 1.2.7.50 | PROC | PROC |
| PR-Z3-UT-EL-156-0070 |  | NMR 602 - PVC Conduits (Walkway & Landscape Lights) |  | 4.8d | 2016-12-21 | 2016-12-27 | PR-Z3-UT-EL-156-0060 | 265.8d | 0d |  |  | OK | 1.2.7.50 | PROC | PROC |
| PR-Z3-UT-EL-156-0080 |  | Start of Material Delivery - PVC Conduits (Walkway & Landscape Lights) | milestone | 0d | 2016-12-27 | 2016-12-27 | PR-Z3-UT-EL-156-0070 | 265.8d | 0d |  |  | OK | 1.2.7.50 | PROC | PROC |
| PR-Z3-UT-EL-156-0090 |  | Complete Material Delivery - PVC Conduits (Walkway & Landscape Lights) |  | 60d | 2016-12-27 | 2017-03-07 | PR-Z3-UT-EL-156-0080 | 265.8d | 0d | PVC Conduits (Walkway & Landscape Lights [25452 Lm] | 253,683.57 | OK | 1.2.7.50 | PROC | PROC |
| PR-Z3-UT-EL-156-0100 |  | NMR 603 - PVC Conduits (Walkway & Landscape Lights) |  | 8d | 2017-03-07 | 2017-03-16 | PR-Z3-UT-EL-156-0090 | 265.8d | 183.6d |  |  | OK | 1.2.7.50 | PROC | PROC |
|  | 6 | **MECHANICAL WORKS (MATERIALS)** |  |  | 2016-09-06 | 2017-06-15 |  |  |  |  |  |  |  |  |  |
|  | 1 | **Odor Control System Accessories** |  |  | 2016-10-05 | 2017-02-22 |  |  |  |  |  |  |  |  |  |
| PR-Z3-GE-GE-237-0010 |  | RFQ - Odor Control System Accessories |  | 8d | 2016-10-05 | 2016-10-15 | PROC-GE-GE-GE-0010 FS+45d | 92.2d | 0d |  |  | OK |  | PROC | PROC |
| PR-Z3-GE-GE-237-0020 |  | Material Submittal - Odor Control System Accessories |  | 8d | 2016-10-15 | 2016-10-24 | PR-Z3-GE-GE-237-0010 | 92.2d | 0d |  |  | OK |  | PROC | PROC |
| PR-Z3-GE-GE-237-0030 |  | Material Approval - Odor Control System Accessories |  | 12d | 2016-10-24 | 2016-11-07 | PR-Z3-GE-GE-237-0020 | 92.2d | 0d |  |  | OK |  | PROC | PROC |
| PR-Z3-GE-GE-237-0040 |  | Technical Evaluation - Odor Control System Accessories |  | 8d | 2016-11-07 | 2016-11-16 | PR-Z3-GE-GE-237-0030 | 92.2d | 0d |  |  | OK |  | PROC | PROC |
| PR-Z3-GE-GE-237-0050 |  | PO - Odor Control System Accessories |  | 12d | 2016-11-16 | 2016-11-30 | PR-Z3-GE-GE-237-0040 | 92.2d | 0d |  |  | OK |  | PROC | PROC |
| PR-Z3-GE-GE-237-0060 |  | NMR 601 - Odor Control System Accessories |  | 12d | 2016-11-30 | 2016-12-14 | PR-Z3-GE-GE-237-0050 | 92.2d | 0d |  |  | OK |  | PROC | PROC |
| PR-Z3-GE-GE-237-0070 |  | NMR 602 - Odor Control System Accessories |  | 12d | 2016-12-14 | 2016-12-28 | PR-Z3-GE-GE-237-0060 | 92.2d | 0d |  |  | OK |  | PROC | PROC |
| PR-Z3-GE-GE-237-0080 |  | Start of Material Delivery - Odor Control System Accessories | milestone | 0d | 2017-01-21 | 2017-01-21 | PR-Z3-GE-GE-237-0070 FS+20d | 92.2d | 0d |  |  | OK |  | PROC | PROC |
| PR-Z3-GE-GE-237-0090 |  | Complete Material Delivery - Odor Control System Accessories |  | 20d | 2017-01-21 | 2017-02-13 | PR-Z3-GE-GE-237-0080 | 284.8d | 0d | Odor Control System Accessories [1 LS] |  | OK |  | PROC | PROC |
| PR-Z3-GE-GE-237-0100 |  | NMR 603 - Odor Control System Accessories |  | 8d | 2017-02-13 | 2017-02-22 | PR-Z3-GE-GE-237-0090 | 284.8d | 202.6d |  |  | OK |  | PROC | PROC |
|  | 2 | **HVAC Ducts, Grills and Accessories** |  |  | 2016-10-11 | 2017-04-09 |  |  |  |  |  |  |  |  |  |
| PR-Z3-GE-GE-238-0010 |  | RFQ - HVAC Ducts, Grills and Accessories |  | 12d | 2016-10-11 | 2016-10-25 | PROC-GE-GE-GE-0010 FS+50d | 173.6d | 0d |  |  | OK |  | PROC | PROC |
| PR-Z3-GE-GE-238-0020 |  | Material Submittal - HVAC Ducts, Grills and Accessories |  | 8d | 2016-10-25 | 2016-11-03 | PR-Z3-GE-GE-238-0010 | 173.6d | 0d |  |  | OK |  | PROC | PROC |
| PR-Z3-GE-GE-238-0030 |  | Material Approval - HVAC Ducts, Grills and Accessories |  | 12d | 2016-11-03 | 2016-11-17 | PR-Z3-GE-GE-238-0020 | 173.6d | 0d |  |  | OK |  | PROC | PROC |
| PR-Z3-GE-GE-238-0040 |  | Technical Evaluation - HVAC Ducts, Grills and Accessories |  | 8d | 2016-11-17 | 2016-11-27 | PR-Z3-GE-GE-238-0030 | 173.6d | 0d |  |  | OK |  | PROC | PROC |
| PR-Z3-GE-GE-238-0050 |  | PO - HVAC Ducts, Grills and Accessories |  | 12d | 2016-11-27 | 2016-12-11 | PR-Z3-GE-GE-238-0040 | 173.6d | 0d |  |  | OK |  | PROC | PROC |
| PR-Z3-GE-GE-238-0060 |  | NMR 601 - HVAC Ducts, Grills and Accessories |  | 12d | 2016-12-11 | 2016-12-25 | PR-Z3-GE-GE-238-0050 | 173.6d | 0d |  |  | OK |  | PROC | PROC |
| PR-Z3-GE-GE-238-0070 |  | NMR 602 - HVAC Ducts, Grills and Accessories |  | 12d | 2016-12-25 | 2017-01-08 | PR-Z3-GE-GE-238-0060 | 173.6d | 0d |  |  | OK |  | PROC | PROC |
| PR-Z3-GE-GE-238-0080 |  | Start of Material Delivery - HVAC Ducts, Grills and Accessories | milestone | 0d | 2017-02-12 | 2017-02-12 | PR-Z3-GE-GE-238-0070 FS+30d | 173.6d | 0d |  |  | OK |  | PROC | PROC |
| PR-Z3-GE-GE-238-0090 |  | Complete Material Delivery - HVAC Ducts, Grills and Accessories |  | 40d | 2017-02-12 | 2017-03-30 | PR-Z3-GE-GE-238-0080 | 245.8d | 0d | HVAC Ducts, Grills and Accessories [1 LS] |  | OK |  | PROC | PROC |
| PR-Z3-GE-GE-238-0100 |  | NMR 603 - HVAC Ducts, Grills and Accessories |  | 8d | 2017-03-30 | 2017-04-09 | PR-Z3-GE-GE-238-0090 | 245.8d | 163.6d |  |  | OK |  | PROC | PROC |

Notes:
- PR-Z3-UT-EL-156-0090: Expenses: (New Expense Item) 253684

| ID | WBS | Activity | Type | Duration | Start | Finish | Predecessors | Total float | Free float | Resources | Wajid | RPI_P2 - PROCUREMENT | RPI_P2 - PHASE |
| --- | --- | --- | --- | --- | --- | --- | --- | --- | --- | --- | --- | --- | --- |
|  | 3 | **FRP Manholes & Lamination** |  |  | 2016-09-06 | 2017-01-19 |  |  |  |  |  |  |  |
| PR-Z3-GE-GE-239-0010 |  | RFQ - FRP Manholes & Lamination |  | 12d | 2016-09-06 | 2016-09-25 | PROC-GE-GE-GE-0010 FS+24d | 313.4d | 0d |  | OK | PROC | PROC |
| PR-Z3-GE-GE-239-0020 |  | Material Submittal - FRP Manholes & Lamination |  | 8d | 2016-09-25 | 2016-10-04 | PR-Z3-GE-GE-239-0010 | 313.4d | 0d |  | OK | PROC | PROC |
| PR-Z3-GE-GE-239-0030 |  | Material Approval - FRP Manholes & Lamination |  | 11.2d | 2016-10-04 | 2016-10-17 | PR-Z3-GE-GE-239-0020 | 313.4d | 0d |  | OK | PROC | PROC |
| PR-Z3-GE-GE-239-0040 |  | Technical Evaluation - FRP Manholes & Lamination |  | 8d | 2016-10-17 | 2016-10-26 | PR-Z3-GE-GE-239-0030 | 313.4d | 0d |  | OK | PROC | PROC |
| PR-Z3-GE-GE-239-0050 |  | PO - FRP Manholes & Lamination |  | 11.2d | 2016-10-26 | 2016-11-08 | PR-Z3-GE-GE-239-0040 | 313.4d | 0d |  | OK | PROC | PROC |
| PR-Z3-GE-GE-239-0060 |  | NMR 601 - FRP Manholes & Lamination |  | 12d | 2016-11-08 | 2016-11-22 | PR-Z3-GE-GE-239-0050 | 313.4d | 0d |  | OK | PROC | PROC |
| PR-Z3-GE-GE-239-0070 |  | NMR 602 - FRP Manholes & Lamination |  | 12d | 2016-11-22 | 2016-12-06 | PR-Z3-GE-GE-239-0060 | 313.4d | 0d |  | OK | PROC | PROC |
| PR-Z3-GE-GE-239-0080 |  | Start of Material Delivery - FRP Manholes & Lamination | milestone | 0d | 2016-12-06 | 2016-12-06 | PR-Z3-GE-GE-239-0070 | 313.4d | 0d |  | OK | PROC | PROC |
| PR-Z3-GE-GE-239-0090 |  | Complete Material Delivery - FRP Manholes & Lamination |  | 30d | 2016-12-06 | 2017-01-10 | PR-Z3-GE-GE-239-0080 | 313.4d | 0d | FRP Manholes & Lamination [300 ea] | OK | PROC | PROC |
| PR-Z3-GE-GE-239-0100 |  | NMR 603 - FRP Manholes & Lamination |  | 8d | 2017-01-10 | 2017-01-19 | PR-Z3-GE-GE-239-0090 | 313.4d | 231.2d |  | OK | PROC | PROC |
|  | 4 | **Window Type AC** |  |  | 2016-10-11 | 2017-04-15 |  |  |  |  |  |  |  |
| PR-Z3-GE-GE-240-0010 |  | RFQ - Window Type AC |  | 6d | 2016-10-11 | 2016-10-18 | PROC-GE-GE-GE-0010 FS+50d | 240d | 0d |  | OK | PROC | PROC |
| PR-Z3-GE-GE-240-0020 |  | Material Submittal - Window Type AC |  | 8d | 2016-11-24 | 2016-12-04 | PR-Z3-GE-GE-240-0010 FS+32d | 240d | 0d |  | OK | PROC | PROC |
| PR-Z3-GE-GE-240-0030 |  | Material Approval - Window Type AC |  | 11.2d | 2016-12-04 | 2016-12-17 | PR-Z3-GE-GE-240-0020 | 240d | 0d |  | OK | PROC | PROC |
| PR-Z3-GE-GE-240-0040 |  | Technical Evaluation - Window Type AC |  | 6d | 2016-12-17 | 2016-12-24 | PR-Z3-GE-GE-240-0030 | 240d | 0d |  | OK | PROC | PROC |
| PR-Z3-GE-GE-240-0050 |  | PO - Window Type AC |  | 7d | 2016-12-24 | 2017-01-01 | PR-Z3-GE-GE-240-0040 | 240d | 0d |  | OK | PROC | PROC |
| PR-Z3-GE-GE-240-0060 |  | NMR 601 - Window Type AC |  | 4.8d | 2017-01-01 | 2017-01-07 | PR-Z3-GE-GE-240-0050 | 240d | 0d |  | OK | PROC | PROC |
| PR-Z3-GE-GE-240-0070 |  | NMR 602 - Window Type AC |  | 4.8d | 2017-01-07 | 2017-01-11 | PR-Z3-GE-GE-240-0060 | 240d | 0d |  | OK | PROC | PROC |
| PR-Z3-GE-GE-240-0080 |  | Start of Material Delivery - Window Type AC | milestone | 0d | 2017-03-23 | 2017-03-23 | PR-Z3-GE-GE-240-0070 FS+60d | 240d | 0d |  | OK | PROC | PROC |
| PR-Z3-GE-GE-240-0090 |  | Complete Material Delivery - Window Type AC |  | 12d | 2017-03-23 | 2017-04-05 | PR-Z3-GE-GE-240-0080 | 240d | 0d | Window Type AC [4 ea] | OK | PROC | PROC |
| PR-Z3-GE-GE-240-0100 |  | NMR 603 - Window Type AC |  | 8d | 2017-04-06 | 2017-04-15 | PR-Z3-GE-GE-240-0090 | 240d | 157.8d |  | OK | PROC | PROC |
|  | 5 | **Fire Extinguishers** |  |  | 2016-09-15 | 2017-05-22 |  |  |  |  |  |  |  |
| PR-Z3-GE-GE-241-0010 |  | RFQ - Fire Extinguishers |  | 8d | 2016-09-15 | 2016-09-25 | PROC-GE-GE-GE-0010 FS+28d | 139.2d | 0d |  | OK | PROC | PROC |
| PR-Z3-GE-GE-241-0020 |  | Material Submittal - Fire Extinguishers |  | 8d | 2016-09-25 | 2016-10-04 | PR-Z3-GE-GE-241-0010 | 139.2d | 0d |  | OK | PROC | PROC |
| PR-Z3-GE-GE-241-0030 |  | Material Approval - Fire Extinguishers |  | 11.2d | 2016-10-04 | 2016-10-17 | PR-Z3-GE-GE-241-0020 | 139.2d | 0d |  | OK | PROC | PROC |
| PR-Z3-GE-GE-241-0040 |  | Technical Evaluation - Fire Extinguishers |  | 8d | 2016-10-17 | 2016-10-26 | PR-Z3-GE-GE-241-0030 | 139.2d | 0d |  | OK | PROC | PROC |
| PR-Z3-GE-GE-241-0050 |  | PO - Fire Extinguishers |  | 11.2d | 2016-10-26 | 2016-11-08 | PR-Z3-GE-GE-241-0040 | 139.2d | 0d |  | OK | PROC | PROC |
| PR-Z3-GE-GE-241-0060 |  | NMR 601 - Fire Extinguishers |  | 12d | 2016-11-08 | 2016-11-22 | PR-Z3-GE-GE-241-0050 | 139.2d | 0d |  | OK | PROC | PROC |
| PR-Z3-GE-GE-241-0070 |  | NMR 602 - Fire Extinguishers |  | 12d | 2016-11-22 | 2016-12-06 | PR-Z3-GE-GE-241-0060 | 139.2d | 0d |  | OK | PROC | PROC |
| PR-Z3-GE-GE-241-0080 |  | Start of Material Delivery - Fire Extinguishers | milestone | 0d | 2017-04-25 | 2017-04-25 | PR-Z3-GE-GE-241-0070 FS+120d | 139.2d | 0d |  | OK | PROC | PROC |
| PR-Z3-GE-GE-241-0090 |  | Complete Material Delivery - Fire Extinguishers |  | 15d | 2017-04-25 | 2017-05-13 | PR-Z3-GE-GE-241-0080 | 208.4d | 0d | Fire Extinguishers [16 ea] | OK | PROC | PROC |
| PR-Z3-GE-GE-241-0100 |  | NMR 603 - Fire Extinguishers |  | 8d | 2017-05-13 | 2017-05-22 | PR-Z3-GE-GE-241-0090 | 208.4d | 126.2d |  | OK | PROC | PROC |

| ID | WBS | Activity | Type | Duration | Start | Finish | Predecessors | Total float | Free float | Resources | Wajid | RPI_P2 - PROCUREMENT | RPI_P2 - PHASE |
| --- | --- | --- | --- | --- | --- | --- | --- | --- | --- | --- | --- | --- | --- |
|  | 6 | **Package Type AC** |  |  | 2016-09-20 | 2017-04-16 |  |  |  |  |  |  |  |
| PR-Z3-GE-GE-242-0010 |  | RFQ - Package Type AC |  | 12d | 2016-09-20 | 2016-10-04 | PROC-GE-GE-GE-0010 FS+32d | 109.2d | 0d |  | OK | PROC | PROC |
| PR-Z3-GE-GE-242-0020 |  | Material Submittal - Package Type AC |  | 8d | 2016-10-04 | 2016-10-13 | PR-Z3-GE-GE-242-0010 | 109.2d | 0d |  | OK | PROC | PROC |
| PR-Z3-GE-GE-242-0030 |  | Material Approval - Package Type AC |  | 11.2d | 2016-10-13 | 2016-10-26 | PR-Z3-GE-GE-242-0020 | 109.2d | 0d |  | OK | PROC | PROC |
| PR-Z3-GE-GE-242-0040 |  | Technical Evaluation - Package Type AC |  | 8d | 2016-10-26 | 2016-11-05 | PR-Z3-GE-GE-242-0030 | 109.2d | 0d |  | OK | PROC | PROC |
| PR-Z3-GE-GE-242-0050 |  | PO - Package Type AC |  | 11.2d | 2016-11-05 | 2016-11-17 | PR-Z3-GE-GE-242-0040 | 109.2d | 0d |  | OK | PROC | PROC |
| PR-Z3-GE-GE-242-0060 |  | NMR 601 - Package Type AC |  | 18d | 2016-11-17 | 2016-12-08 | PR-Z3-GE-GE-242-0050 | 109.2d | 0d |  | OK | PROC | PROC |
| PR-Z3-GE-GE-242-0070 |  | NMR 602 - Package Type AC |  | 18d | 2016-12-08 | 2016-12-29 | PR-Z3-GE-GE-242-0060 | 109.2d | 0d |  | OK | PROC | PROC |
| PR-Z3-GE-GE-242-0080 |  | Start of Material Delivery - Package Type AC | milestone | 0d | 2017-03-23 | 2017-03-23 | PR-Z3-GE-GE-242-0070 FS+72d | 109.2d | 0d |  | OK | PROC | PROC |
| PR-Z3-GE-GE-242-0090 |  | Complete Material Delivery - Package Type AC |  | 12d | 2017-03-23 | 2017-04-06 | PR-Z3-GE-GE-242-0080 | 239.4d | 0d | Package Type AC [6 ea] | OK | PROC | PROC |
| PR-Z3-GE-GE-242-0100 |  | NMR 603 - Package Type AC |  | 8d | 2017-04-06 | 2017-04-16 | PR-Z3-GE-GE-242-0090 | 239.4d | 157.2d |  | OK | PROC | PROC |
|  | 7 | **DDC Panels (HVAC for Lift Stations)** |  |  | 2016-10-09 | 2017-04-13 |  |  |  |  |  |  |  |
| PR-Z3-GE-GE-243-0010 |  | RFQ - DDC Panels (HVAC for Lift Stations) |  | 12d | 2016-10-09 | 2016-10-23 | PROC-GE-GE-GE-0010 FS+48d | 118.8d | 0d |  | OK | PROC | PROC |
| PR-Z3-GE-GE-243-0020 |  | Material Submittal - DDC Panels (HVAC for Lift Stations) |  | 8d | 2016-10-23 | 2016-11-01 | PR-Z3-GE-GE-243-0010 | 118.8d | 0d |  | OK | PROC | PROC |
| PR-Z3-GE-GE-243-0030 |  | Material Approval - DDC Panels (HVAC for Lift Stations) |  | 11.2d | 2016-11-01 | 2016-11-14 | PR-Z3-GE-GE-243-0020 | 118.8d | 0d |  | OK | PROC | PROC |
| PR-Z3-GE-GE-243-0040 |  | Technical Evaluation - DDC Panels (HVAC for Lift Stations) |  | 8d | 2016-11-14 | 2016-11-23 | PR-Z3-GE-GE-243-0030 | 118.8d | 0d |  | OK | PROC | PROC |
| PR-Z3-GE-GE-243-0050 |  | PO - DDC Panels (HVAC for Lift Stations) |  | 11.2d | 2016-11-23 | 2016-12-06 | PR-Z3-GE-GE-243-0040 | 118.8d | 0d |  | OK | PROC | PROC |
| PR-Z3-GE-GE-243-0060 |  | NMR 601 - DDC Panels (HVAC for Lift Stations) |  | 12d | 2016-12-06 | 2016-12-20 | PR-Z3-GE-GE-243-0050 | 118.8d | 0d |  | OK | PROC | PROC |
| PR-Z3-GE-GE-243-0070 |  | NMR 602 - DDC Panels (HVAC for Lift Stations) |  | 12d | 2016-12-20 | 2017-01-03 | PR-Z3-GE-GE-243-0060 | 118.8d | 0d |  | OK | PROC | PROC |
| PR-Z3-GE-GE-243-0080 |  | Start of Material Delivery - DDC Panels (HVAC for Lift Stations) | milestone | 0d | 2017-03-14 | 2017-03-14 | PR-Z3-GE-GE-243-0070 FS+60d | 118.8d | 0d |  | OK | PROC | PROC |
| PR-Z3-GE-GE-243-0090 |  | Complete Material Delivery - DDC Panels (HVAC for Lift Stations) |  | 18d | 2017-03-14 | 2017-04-04 | PR-Z3-GE-GE-243-0080 | 241.4d | 0d | DDC Panels (HVAC for Lift Stations) [3 ea] | OK | PROC | PROC |
| PR-Z3-GE-GE-243-0100 |  | NMR 603 - DDC Panels (HVAC for Lift Stations) |  | 8d | 2017-04-04 | 2017-04-13 | PR-Z3-GE-GE-243-0090 | 241.4d | 159.2d |  | OK | PROC | PROC |
|  | 8 | **Fire Alarm System** |  |  | 2016-09-18 | 2017-06-15 |  |  |  |  |  |  |  |
| PR-Z3-GE-GE-244-0010 |  | RFQ - Fire Alarm System |  | 12d | 2016-09-18 | 2016-10-02 | PROC-GE-GE-GE-0010 FS+30d | 84.8d | 0d |  | OK | PROC | PROC |
| PR-Z3-GE-GE-244-0020 |  | Material Submittal - Fire Alarm System |  | 8d | 2016-12-01 | 2016-12-11 | PR-Z3-GE-GE-244-0010 FS+52d | 84.8d | 0d |  | OK | PROC | PROC |
| PR-Z3-GE-GE-244-0030 |  | Material Approval - Fire Alarm System |  | 11.2d | 2016-12-11 | 2016-12-24 | PR-Z3-GE-GE-244-0020 | 84.8d | 0d |  | OK | PROC | PROC |
| PR-Z3-GE-GE-244-0040 |  | Technical Evaluation - Fire Alarm System |  | 8d | 2016-12-24 | 2017-01-02 | PR-Z3-GE-GE-244-0030 | 84.8d | 0d |  | OK | PROC | PROC |
| PR-Z3-GE-GE-244-0050 |  | PO - Fire Alarm System |  | 11.2d | 2017-01-02 | 2017-01-15 | PR-Z3-GE-GE-244-0040 | 84.8d | 0d |  | OK | PROC | PROC |
| PR-Z3-GE-GE-244-0060 |  | NMR 601 - Fire Alarm System |  | 12d | 2017-01-15 | 2017-01-29 | PR-Z3-GE-GE-244-0050 | 84.8d | 0d |  | OK | PROC | PROC |
| PR-Z3-GE-GE-244-0070 |  | NMR 602 - Fire Alarm System |  | 12d | 2017-01-29 | 2017-02-12 | PR-Z3-GE-GE-244-0060 | 84.8d | 0d |  | OK | PROC | PROC |
| PR-Z3-GE-GE-244-0080 |  | Start of Material Delivery - Fire Alarm System | milestone | 0d | 2017-04-23 | 2017-04-23 | PR-Z3-GE-GE-244-0070 FS+60d | 84.8d | 0d |  | OK | PROC | PROC |
| PR-Z3-GE-GE-244-0090 |  | Complete Material Delivery - Fire Alarm System |  | 30d | 2017-05-02 | 2017-06-06 | PR-Z3-GE-GE-244-0080 FS+8d | 187.4d | 0d | Fire Alarm System [1 LS] | OK | PROC | PROC |
| PR-Z3-GE-GE-244-0100 |  | NMR 603 - Fire Alarm System |  | 8d | 2017-06-06 | 2017-06-15 | PR-Z3-GE-GE-244-0090 | 187.4d | 105.2d |  | OK | PROC | PROC |

| ID | WBS | Activity | Type | Duration | Start | Finish | Predecessors | Total float | Free float | Resources | Cost | Wajid | RPI_P2 - BOQ ITEMS | RPI_P2 - PROCUREMENT | RPI_P2 - PHASE |
| --- | --- | --- | --- | --- | --- | --- | --- | --- | --- | --- | --- | --- | --- | --- | --- |
|  | 3 | **MATERIAL FOR ZONE - 4** |  |  | 2016-08-23 | 2017-06-07 |  |  |  |  |  |  |  |  |  |
|  | 1 | **CIVIL WORKS - (MATERIAL)** |  |  | 2016-09-18 | 2017-06-07 |  |  |  |  |  |  |  |  |  |
|  | 1 | **Concrete Works related Material** |  |  | 2016-09-18 | 2017-04-30 |  |  |  |  |  |  |  |  |  |
|  | 1 | **Polyethene Sheets** |  |  | 2016-09-24 | 2017-02-20 |  |  |  |  |  |  |  |  |  |
| PR-Z4-CW-CW-157-0010 |  | RFQ - Polyethene Sheets |  | 12d | 2016-09-24 | 2016-10-08 | PROC-GE-GE-GE-0010 FS+35d | 286.8d | 0d |  |  | OK | 1.2.8.10 | PROC | PROC |
| PR-Z4-CW-CW-157-0020 |  | Material Submittal - Polyethene Sheets |  | 8d | 2016-10-08 | 2016-10-17 | PR-Z4-CW-CW-157-0010 | 286.8d | 0d |  |  | OK | 1.2.8.10 | PROC | PROC |
| PR-Z4-CW-CW-157-0030 |  | Material Approval - Polyethene Sheets |  | 11.2d | 2016-10-17 | 2016-10-30 | PR-Z4-CW-CW-157-0020 | 286.8d | 0d |  |  | OK | 1.2.8.10 | PROC | PROC |
| PR-Z4-CW-CW-157-0040 |  | Technical Evaluation - Polyethene Sheets |  | 8d | 2016-10-30 | 2016-11-08 | PR-Z4-CW-CW-157-0030 | 286.8d | 0d |  |  | OK | 1.2.8.10 | PROC | PROC |
| PR-Z4-CW-CW-157-0050 |  | PO - Polyethene Sheets |  | 11.2d | 2016-11-08 | 2016-11-21 | PR-Z4-CW-CW-157-0040 | 286.8d | 0d |  |  | OK | 1.2.8.10 | PROC | PROC |
| PR-Z4-CW-CW-157-0060 |  | NMR 601 - Polyethene Sheets |  | 4.8d | 2016-11-21 | 2016-11-27 | PR-Z4-CW-CW-157-0050 | 286.8d | 0d |  |  | OK | 1.2.8.10 | PROC | PROC |
| PR-Z4-CW-CW-157-0070 |  | NMR 602 - Polyethene Sheets |  | 4.8d | 2016-11-27 | 2016-12-03 | PR-Z4-CW-CW-157-0060 | 286.8d | 0d |  |  | OK | 1.2.8.10 | PROC | PROC |
| PR-Z4-CW-CW-157-0080 |  | Start of Material Delivery - Polyethene Sheets | milestone | 0d | 2016-12-03 | 2016-12-03 | PR-Z4-CW-CW-157-0070 | 286.8d | 0d |  |  | OK | 1.2.8.10 | PROC | PROC |
| PR-Z4-CW-CW-157-0090 |  | Complete Material Delivery - Polyethene Sheets |  | 60d | 2016-12-03 | 2017-02-11 | PR-Z4-CW-CW-157-0080 | 286.8d | 0d | Polyethene Sheet [4630 Sqm] | 11,877.2 | OK | 1.2.8.10 | PROC | PROC |
| PR-Z4-CW-CW-157-0100 |  | NMR 603 - Polyethene Sheets |  | 8d | 2017-02-11 | 2017-02-20 | PR-Z4-CW-CW-157-0090 | 286.8d | 204.6d |  |  | OK | 1.2.8.10 | PROC | PROC |
|  | 2 | **Bituminus Paints** |  |  | 2016-11-03 | 2017-03-27 |  |  |  |  |  |  |  |  |  |
| PR-Z4-CW-CW-158-0010 |  | RFQ - Bituminus Paints |  | 5.6d | 2016-11-03 | 2016-11-10 | PROC-GE-GE-GE-0010 FS+70.4d | 256.2d | 0d |  |  | OK | 1.2.8.10 | PROC | PROC |
| PR-Z4-CW-CW-158-0020 |  | Material Submittal - Bituminus Paints |  | 8d | 2016-11-10 | 2016-11-20 | PR-Z4-CW-CW-158-0010 | 256.2d | 0d |  |  | OK | 1.2.8.10 | PROC | PROC |
| PR-Z4-CW-CW-158-0030 |  | Material Approval - Bituminus Paints |  | 11.2d | 2016-11-20 | 2016-12-03 | PR-Z4-CW-CW-158-0020 | 256.2d | 0d |  |  | OK | 1.2.8.10 | PROC | PROC |
| PR-Z4-CW-CW-158-0040 |  | Technical Evaluation - Bituminus Paints |  | 8d | 2016-12-03 | 2016-12-12 | PR-Z4-CW-CW-158-0030 | 256.2d | 0d |  |  | OK | 1.2.8.10 | PROC | PROC |
| PR-Z4-CW-CW-158-0050 |  | PO - Bituminus Paints |  | 11.2d | 2016-12-12 | 2016-12-25 | PR-Z4-CW-CW-158-0040 | 256.2d | 0d |  |  | OK | 1.2.8.10 | PROC | PROC |
| PR-Z4-CW-CW-158-0060 |  | NMR 601 - Bituminus Paints |  | 4.8d | 2016-12-25 | 2016-12-31 | PR-Z4-CW-CW-158-0050 | 256.2d | 0d |  |  | OK | 1.2.8.10 | PROC | PROC |
| PR-Z4-CW-CW-158-0070 |  | NMR 602 - Bituminus Paints |  | 4.8d | 2016-12-31 | 2017-01-05 | PR-Z4-CW-CW-158-0060 | 256.2d | 0d |  |  | OK | 1.2.8.10 | PROC | PROC |
| PR-Z4-CW-CW-158-0080 |  | Start of Material Delivery - Bituminus Paints | milestone | 0d | 2017-01-11 | 2017-01-11 | PR-Z4-CW-CW-158-0070 FS+4.8d | 256.2d | 0d |  |  | OK | 1.2.8.10 | PROC | PROC |
| PR-Z4-CW-CW-158-0090 |  | Complete Material Delivery - Bituminus Paints |  | 60d | 2017-01-11 | 2017-03-21 | PR-Z4-CW-CW-158-0080 | 256.2d | 0d | Bituminus Paint [1087 Sqm] | 19,762.8 | OK | 1.2.8.10 | PROC | PROC |
| PR-Z4-CW-CW-158-0100 |  | NMR 603 - Bituminus Paints |  | 4.8d | 2017-03-22 | 2017-03-27 | PR-Z4-CW-CW-158-0090 | 256.2d | 174d |  |  | OK | 1.2.8.10 | PROC | PROC |

Notes:
- PR-Z4-CW-CW-157-0090: Expenses: (New Expense Item) 11877.2
- PR-Z4-CW-CW-158-0090: Expenses: (New Expense Item) 19762.8

| ID | WBS | Activity | Type | Duration | Start | Finish | Predecessors | Total float | Free float | Resources | Cost | Wajid | RPI_P2 - BOQ ITEMS | RPI_P2 - PROCUREMENT | RPI_P2 - PHASE |
| --- | --- | --- | --- | --- | --- | --- | --- | --- | --- | --- | --- | --- | --- | --- | --- |
|  | 3 | **Backfill (Bed Preparation)** |  |  | 2016-10-05 | 2017-03-04 |  |  |  |  |  |  |  |  |  |
| PR-Z4-CW-CW-159-0010 |  | RFQ - Backfill (Bed Preparation) |  | 12d | 2016-10-05 | 2016-10-19 | PROC-GE-GE-GE-0010 FS+45d | 276.8d | 0d |  |  | OK | 1.2.8.10 | PROC | PROC |
| PR-Z4-CW-CW-159-0020 |  | Material Submittal - Backfill (Bed Preparation) |  | 8d | 2016-10-19 | 2016-10-29 | PR-Z4-CW-CW-159-0010 | 276.8d | 0d |  |  | OK | 1.2.8.10 | PROC | PROC |
| PR-Z4-CW-CW-159-0030 |  | Material Approval - Backfill (Bed Preparation) |  | 11.2d | 2016-10-29 | 2016-11-10 | PR-Z4-CW-CW-159-0020 | 276.8d | 0d |  |  | OK | 1.2.8.10 | PROC | PROC |
| PR-Z4-CW-CW-159-0040 |  | Technical Evaluation - Backfill (Bed Preparation) |  | 8d | 2016-11-10 | 2016-11-20 | PR-Z4-CW-CW-159-0030 | 276.8d | 0d |  |  | OK | 1.2.8.10 | PROC | PROC |
| PR-Z4-CW-CW-159-0050 |  | PO - Backfill (Bed Preparation) |  | 11.2d | 2016-11-20 | 2016-12-03 | PR-Z4-CW-CW-159-0040 | 276.8d | 0d |  |  | OK | 1.2.8.10 | PROC | PROC |
| PR-Z4-CW-CW-159-0060 |  | NMR 601 - Backfill (Bed Preparation) |  | 4.8d | 2016-12-03 | 2016-12-08 | PR-Z4-CW-CW-159-0050 | 276.8d | 0d |  |  | OK | 1.2.8.10 | PROC | PROC |
| PR-Z4-CW-CW-159-0070 |  | NMR 602 - Backfill (Bed Preparation) |  | 4.8d | 2016-12-08 | 2016-12-14 | PR-Z4-CW-CW-159-0060 | 276.8d | 0d |  |  | OK | 1.2.8.10 | PROC | PROC |
| PR-Z4-CW-CW-159-0080 |  | Start of Material Delivery - Backfill (Bed Preparation) | milestone | 0d | 2016-12-14 | 2016-12-14 | PR-Z4-CW-CW-159-0070 | 276.8d | 0d |  |  | OK | 1.2.8.10 | PROC | PROC |
| PR-Z4-CW-CW-159-0090 |  | Complete Material Delivery - Backfill (Bed Preparation) |  | 60d | 2016-12-14 | 2017-02-22 | PR-Z4-CW-CW-159-0080 | 276.8d | 0d |  | 29,193.28 | OK | 1.2.8.10 | PROC | PROC |
| PR-Z4-CW-CW-159-0100 |  | NMR 603 - Backfill (Bed Preparation) |  | 8d | 2017-02-22 | 2017-03-04 | PR-Z4-CW-CW-159-0090 | 276.8d | 194.6d |  |  | OK | 1.2.8.10 | PROC | PROC |
|  | 4 | **Ready Mix Concrete** |  |  | 2016-09-18 | 2017-04-30 |  |  |  |  |  |  |  |  |  |
| PR-Z4-CW-CW-160-0010 |  | RFQ - Ready Mix Concrete |  | 12d | 2016-09-18 | 2016-10-02 | PROC-GE-GE-GE-0010 FS+30d | 227d | 0d |  |  | OK | 1.2.8.10 | PROC | PROC |
| PR-Z4-CW-CW-160-0020 |  | Material Submittal - Ready Mix Concrete |  | 5.6d | 2016-10-02 | 2016-10-08 | PR-Z4-CW-CW-160-0010 | 227d | 0d |  |  | OK | 1.2.8.10 | PROC | PROC |
| PR-Z4-CW-CW-160-0030 |  | Material Approval - Ready Mix Concrete |  | 10d | 2016-10-08 | 2016-10-19 | PR-Z4-CW-CW-160-0020 | 227d | 0d |  |  | OK | 1.2.8.10 | PROC | PROC |
| PR-Z4-CW-CW-160-0040 |  | Technical Evaluation - Ready Mix Concrete |  | 12d | 2016-10-19 | 2016-11-02 | PR-Z4-CW-CW-160-0030 | 227d | 0d |  |  | OK | 1.2.8.10 | PROC | PROC |
| PR-Z4-CW-CW-160-0050 |  | PO - Ready Mix Concrete |  | 12d | 2016-11-02 | 2016-11-16 | PR-Z4-CW-CW-160-0040 | 227d | 0d |  |  | OK | 1.2.8.10 | PROC | PROC |
| PR-Z4-CW-CW-160-0060 |  | NMR 601 - Ready Mix Concrete |  | 1.6d | 2016-11-16 | 2016-11-19 | PR-Z4-CW-CW-160-0050 | 227d | 0d |  |  | OK | 1.2.8.10 | PROC | PROC |
| PR-Z4-CW-CW-160-0070 |  | NMR 602 - Ready Mix Concrete |  | 1.6d | 2016-11-19 | 2016-11-20 | PR-Z4-CW-CW-160-0060 | 227d | 0d |  |  | OK | 1.2.8.10 | PROC | PROC |
| PR-Z4-CW-CW-160-0080 |  | Start of Material Delivery - Ready Mix Concrete | milestone | 0d | 2016-11-21 | 2016-11-21 | PR-Z4-CW-CW-160-0070 | 227d | 0d |  |  | OK | 1.2.8.10 | PROC | PROC |
| PR-Z4-CW-CW-160-0090 |  | Complete Material Delivery - Ready Mix Concrete |  | 130d | 2016-11-21 | 2017-04-20 | PR-Z4-CW-CW-160-0080 | 227d | 0d | Ready Mix Concrete [757 m³] | 615,985.07 | OK | 1.2.8.10 | PROC | PROC |
| PR-Z4-CW-CW-160-0100 |  | NMR 603 - Ready Mix Concrete |  | 8d | 2017-04-22 | 2017-04-30 | PR-Z4-CW-CW-160-0090 | 227d | 144.8d |  |  | OK | 1.2.8.10 | PROC | PROC |
|  | 2 | **All Other Miscellaneous Items** |  |  | 2016-09-24 | 2017-06-07 |  |  |  |  |  |  |  |  |  |
|  | 1 | **4.0 Wide Patrol Road Material (maitaining existing patrol road)** |  |  | 2016-10-13 | 2017-06-07 |  |  |  |  |  |  |  |  |  |
| PR-Z4-CW-CW-161-0010 |  | RFQ - 4.0 m Wide Patrol Road Material (maitaining existing patrol road) |  | 5.6d | 2016-10-13 | 2016-10-19 | PROC-GE-GE-GE-0010 FS+52d | 194.2d | 0d |  |  | OK | 1.2.8.20 | PROC | PROC |
| PR-Z4-CW-CW-161-0020 |  | Material Submittal - 4.0 m Wide Patrol Road Material (maitaining existing patrol road) |  | 8d | 2016-10-19 | 2016-10-29 | PR-Z4-CW-CW-161-0010 | 194.2d | 0d |  |  | OK | 1.2.8.20 | PROC | PROC |
| PR-Z4-CW-CW-161-0030 |  | Material Approval - 4.0 m Wide Patrol Road Material (maitaining existing patrol road) |  | 11.2d | 2016-10-29 | 2016-11-10 | PR-Z4-CW-CW-161-0020 | 194.2d | 0d |  |  | OK | 1.2.8.20 | PROC | PROC |
| PR-Z4-CW-CW-161-0040 |  | Technical Evaluation - 4.0 m Wide Patrol Road Material (maitaining existing patrol road) |  | 8d | 2016-11-12 | 2016-11-20 | PR-Z4-CW-CW-161-0030 | 194.2d | 0d |  |  | OK | 1.2.8.20 | PROC | PROC |
| PR-Z4-CW-CW-161-0050 |  | PO - 4.0 m Wide Patrol Road Material (maitaining existing patrol road) |  | 11.2d | 2016-11-21 | 2016-12-04 | PR-Z4-CW-CW-161-0040 | 194.2d | 0d |  |  | OK | 1.2.8.20 | PROC | PROC |
| PR-Z4-CW-CW-161-0060 |  | NMR 601 - 4.0 m Wide Patrol Road Material (maitaining existing patrol road) |  | 4.8d | 2016-12-04 | 2016-12-08 | PR-Z4-CW-CW-161-0050 | 194.2d | 0d |  |  | OK | 1.2.8.20 | PROC | PROC |
| PR-Z4-CW-CW-161-0070 |  | NMR 602 - 4.0 m Wide Patrol Road Material (maitaining existing patrol road) |  | 4.8d | 2016-12-10 | 2016-12-14 | PR-Z4-CW-CW-161-0060 | 194.2d | 0d |  |  | OK | 1.2.8.20 | PROC | PROC |
| PR-Z4-CW-CW-161-0080 |  | Start of Material Delivery - 4.0 m Wide Patrol Road Material (maitaining existing patrol road) | milestone | 0d | 2016-12-14 | 2016-12-14 | PR-Z4-CW-CW-161-0070 | 194.2d | 0d |  |  | OK | 1.2.8.20 | PROC | PROC |
| PR-Z4-CW-CW-161-0090 |  | Complete Material Delivery - 4.0 m Wide Patrol Road Material (maitaining existing patrol road) |  | 150d | 2016-12-14 | 2017-06-07 | PR-Z4-CW-CW-161-0080 | 194.2d | 112d |  | 160,212.37 | OK | 1.2.8.20 | PROC | PROC |

Notes:
- PR-Z4-CW-CW-159-0090: Expenses: (New Expense Item) 29193.3
- PR-Z4-CW-CW-160-0090: Expenses: (New Expense Item) 615985
- PR-Z4-CW-CW-161-0090: Expenses: (New Expense Item) 160212

| ID | WBS | Activity | Type | Duration | Start | Finish | Predecessors | Total float | Free float | Resources | Cost | Wajid | RPI_P2 - BOQ ITEMS | RPI_P2 - PROCUREMENT | RPI_P2 - PHASE |
| --- | --- | --- | --- | --- | --- | --- | --- | --- | --- | --- | --- | --- | --- | --- | --- |
|  | 2 | **Traffic Signage** |  |  | 2016-11-13 | 2017-06-01 |  |  |  |  |  |  |  |  |  |
| PR-Z4-CW-CW-162-0010 |  | RFQ - Traffic Signage |  | 5.6d | 2016-11-13 | 2016-11-19 | PROC-GE-GE-GE-0010 FS+78d | 199d | 0d |  |  | OK | 1.2.8.20 | PROC | PROC |
| PR-Z4-CW-CW-162-0020 |  | Material Submittal - Traffic Signage |  | 8d | 2016-11-19 | 2016-11-28 | PR-Z4-CW-CW-162-0010 | 199d | 0d |  |  | OK | 1.2.8.20 | PROC | PROC |
| PR-Z4-CW-CW-162-0030 |  | Material Approval - Traffic Signage |  | 11.2d | 2016-11-28 | 2016-12-11 | PR-Z4-CW-CW-162-0020 | 199d | 0d |  |  | OK | 1.2.8.20 | PROC | PROC |
| PR-Z4-CW-CW-162-0040 |  | Technical Evaluation - Traffic Signage |  | 8d | 2016-12-12 | 2016-12-20 | PR-Z4-CW-CW-162-0030 | 199d | 0d |  |  | OK | 1.2.8.20 | PROC | PROC |
| PR-Z4-CW-CW-162-0050 |  | PO - Traffic Signage |  | 11.2d | 2016-12-21 | 2017-01-03 | PR-Z4-CW-CW-162-0040 | 199d | 0d |  |  | OK | 1.2.8.20 | PROC | PROC |
| PR-Z4-CW-CW-162-0060 |  | NMR 601 - Traffic Signage |  | 12d | 2017-01-03 | 2017-01-17 | PR-Z4-CW-CW-162-0050 | 199d | 0d |  |  | OK | 1.2.8.20 | PROC | PROC |
| PR-Z4-CW-CW-162-0070 |  | NMR 602 - Traffic Signage |  | 12d | 2017-01-17 | 2017-01-31 | PR-Z4-CW-CW-162-0060 | 199d | 0d |  |  | OK | 1.2.8.20 | PROC | PROC |
| PR-Z4-CW-CW-162-0080 |  | Start of Material Delivery - Traffic Signage | milestone | 0d | 2017-03-15 | 2017-03-15 | PR-Z4-CW-CW-162-0070 FS+36.8d | 199d | 0d |  |  | OK | 1.2.8.20 | PROC | PROC |
| PR-Z4-CW-CW-162-0090 |  | Complete Material Delivery - Traffic Signage |  | 60d | 2017-03-15 | 2017-05-23 | PR-Z4-CW-CW-162-0080 | 199d | 0d | Traffic Signage [1 ea] | 5,906.17 | OK | 1.2.8.20 | PROC | PROC |
| PR-Z4-CW-CW-162-0100 |  | NMR 603 - Traffic Signage |  | 8d | 2017-05-24 | 2017-06-01 | PR-Z4-CW-CW-162-0090 | 199d | 116.8d |  |  | OK | 1.2.8.20 | PROC | PROC |
|  | 3 | **Road Marking Paint** |  |  | 2016-09-24 | 2017-01-24 |  |  |  |  |  |  |  |  |  |
| PR-Z4-CW-CW-163-0010 |  | RFQ - Road Marking Paint |  | 12d | 2016-09-24 | 2016-10-08 | PROC-GE-GE-GE-0010 FS+35d | 309.6d | 0d |  |  | OK | 1.2.8.20 | PROC | PROC |
| PR-Z4-CW-CW-163-0020 |  | Material Submittal - Road Marking Paint |  | 8d | 2016-10-08 | 2016-10-17 | PR-Z4-CW-CW-163-0010 | 309.6d | 0d |  |  | OK | 1.2.8.20 | PROC | PROC |
| PR-Z4-CW-CW-163-0030 |  | Material Approval - Road Marking Paint |  | 11.2d | 2016-10-17 | 2016-10-30 | PR-Z4-CW-CW-163-0020 | 309.6d | 0d |  |  | OK | 1.2.8.20 | PROC | PROC |
| PR-Z4-CW-CW-163-0040 |  | Technical Evaluation - Road Marking Paint |  | 8d | 2016-10-30 | 2016-11-08 | PR-Z4-CW-CW-163-0030 | 309.6d | 0d |  |  | OK | 1.2.8.20 | PROC | PROC |
| PR-Z4-CW-CW-163-0050 |  | PO - Road Marking Paint |  | 11.2d | 2016-11-08 | 2016-11-21 | PR-Z4-CW-CW-163-0040 | 309.6d | 0d |  |  | OK | 1.2.8.20 | PROC | PROC |
| PR-Z4-CW-CW-163-0060 |  | NMR 601 - Road Marking Paint |  | 12d | 2016-11-21 | 2016-12-05 | PR-Z4-CW-CW-163-0050 | 309.6d | 0d |  |  | OK | 1.2.8.20 | PROC | PROC |
| PR-Z4-CW-CW-163-0070 |  | NMR 602 - Road Marking Paint |  | 12d | 2016-12-05 | 2016-12-19 | PR-Z4-CW-CW-163-0060 | 309.6d | 0d |  |  | OK | 1.2.8.20 | PROC | PROC |
| PR-Z4-CW-CW-163-0080 |  | Start of Material Delivery - Road Marking Paint | milestone | 0d | 2016-12-25 | 2016-12-25 | PR-Z4-CW-CW-163-0070 FS+4.8d | 309.6d | 0d |  |  | OK | 1.2.8.20 | PROC | PROC |
| PR-Z4-CW-CW-163-0090 |  | Complete Material Delivery - Road Marking Paint |  | 18d | 2016-12-25 | 2017-01-15 | PR-Z4-CW-CW-163-0080 | 309.6d | 0d | Road Marking Paint [4070 Sqm] | 115,988.66 | OK | 1.2.8.20 | PROC | PROC |
| PR-Z4-CW-CW-163-0100 |  | NMR 603 - Road Marking Paint |  | 8d | 2017-01-15 | 2017-01-24 | PR-Z4-CW-CW-163-0090 | 309.6d | 227.4d |  |  | OK | 1.2.8.20 | PROC | PROC |
|  | 2 | **ELECTRICAL WORKS (MATERIAL)** |  |  | 2016-08-27 | 2017-03-23 |  |  |  |  |  |  |  |  |  |
|  | 1 | **Medium Voltage Cables** |  |  | 2016-08-27 | 2017-02-23 |  |  |  |  |  |  |  |  |  |
|  | 1 | **MV Cables** |  |  | 2016-09-18 | 2017-02-23 |  |  |  |  |  |  |  |  |  |
| PR-Z4-CW-CW-164-0010 |  | RFQ - MV Cables |  | 6d | 2016-09-18 | 2016-09-25 | PROC-GE-GE-GE-0010 FS+10.4d, PR-Z3-EW-EW-36-0010 SS | 283.2d | 0d |  |  | OK | 1.2.9.10 | PROC | PROC |
| PR-Z4-CW-CW-164-0020 |  | Material Submittal - MV Cables |  | 5.6d | 2016-09-25 | 2016-10-01 | PR-Z4-CW-CW-164-0010 | 283.2d | 0d |  |  | OK | 1.2.9.10 | PROC | PROC |
| PR-Z4-CW-CW-164-0030 |  | Material Approval - MV Cables |  | 11d | 2016-10-01 | 2016-10-13 | PR-Z4-CW-CW-164-0020 | 283.2d | 0d |  |  | OK | 1.2.9.10 | PROC | PROC |
| PR-Z4-CW-CW-164-0040 |  | Technical Evaluation - MV Cables |  | 8d | 2016-10-13 | 2016-10-23 | PR-Z4-CW-CW-164-0030 | 283.2d | 0d |  |  | OK | 1.2.9.10 | PROC | PROC |
| PR-Z4-CW-CW-164-0050 |  | PO - MV Cables |  | 8d | 2016-10-23 | 2016-11-01 | PR-Z4-CW-CW-164-0040 | 283.2d | 0d |  |  | OK | 1.2.9.10 | PROC | PROC |
| PR-Z4-CW-CW-164-0060 |  | NMR 601 - MV Cables |  | 6d | 2016-11-01 | 2016-11-08 | PR-Z4-CW-CW-164-0050 | 283.2d | 0d |  |  | OK | 1.2.9.10 | PROC | PROC |
| PR-Z4-CW-CW-164-0070 |  | NMR 602 - MV Cables |  | 6d | 2016-11-08 | 2016-11-15 | PR-Z4-CW-CW-164-0060 | 283.2d | 0d |  |  | OK | 1.2.9.10 | PROC | PROC |
| PR-Z4-CW-CW-164-0080 |  | Start of Material Delivery - MV Cables | milestone | 0d | 2017-01-10 | 2017-01-10 | PR-Z4-CW-CW-164-0070 FS+48d | 283.2d | 0d |  |  | OK | 1.2.9.10 | PROC | PROC |
| PR-Z4-CW-CW-164-0090 |  | Complete Material Delivery - MV Cables |  | 30d | 2017-01-10 | 2017-02-14 | PR-Z4-CW-CW-164-0080 | 283.2d | 0d | MV Cables [2445 Lm] | 1,016,616.82 | OK | 1.2.9.10 | PROC | PROC |
| PR-Z4-CW-CW-164-0100 |  | NMR 603 - MV Cables |  | 8d | 2017-02-14 | 2017-02-23 | PR-Z4-CW-CW-164-0090 | 283.2d | 201d |  |  | OK | 1.2.9.10 | PROC | PROC |

Notes:
- PR-Z4-CW-CW-162-0090: Expenses: (New Expense Item) 5906.17
- PR-Z4-CW-CW-163-0090: Expenses: (New Expense Item) 115989
- PR-Z4-CW-CW-164-0090: Expenses: (New Expense Item) 1016617

| ID | WBS | Activity | Type | Duration | Start | Finish | Predecessors | Total float | Free float | Resources | Cost | Wajid | RPI_P2 - BOQ ITEMS | RPI_P2 - PROCUREMENT | RPI_P2 - PHASE |
| --- | --- | --- | --- | --- | --- | --- | --- | --- | --- | --- | --- | --- | --- | --- | --- |
|  | 2 | **LV & Grounding Cables** |  |  | 2016-09-18 | 2017-02-15 |  |  |  |  |  |  |  |  |  |
| PR-Z4-CW-CW-165-0010 |  | RFQ - LV & Grounding Cables |  | 5.6d | 2016-09-18 | 2016-09-24 | PROC-GE-GE-GE-0010 FS+30d | 290.6d | 0d |  |  | OK | 1.2.9.10 | PROC | PROC |
| PR-Z4-CW-CW-165-0020 |  | Material Submittal - LV & Grounding Cables |  | 8d | 2016-09-24 | 2016-10-03 | PR-Z4-CW-CW-165-0010 | 290.6d | 0d |  |  | OK | 1.2.9.10 | PROC | PROC |
| PR-Z4-CW-CW-165-0030 |  | Material Approval - LV & Grounding Cables |  | 11.2d | 2016-10-03 | 2016-10-16 | PR-Z4-CW-CW-165-0020 | 290.6d | 0d |  |  | OK | 1.2.9.10 | PROC | PROC |
| PR-Z4-CW-CW-165-0040 |  | Technical Evaluation - LV & Grounding Cables |  | 8d | 2016-10-17 | 2016-10-25 | PR-Z4-CW-CW-165-0030 | 290.6d | 0d |  |  | OK | 1.2.9.10 | PROC | PROC |
| PR-Z4-CW-CW-165-0050 |  | PO - LV & Grounding Cables |  | 11.2d | 2016-10-26 | 2016-11-08 | PR-Z4-CW-CW-165-0040 | 290.6d | 0d |  |  | OK | 1.2.9.10 | PROC | PROC |
| PR-Z4-CW-CW-165-0060 |  | NMR 601 - LV & Grounding Cables |  | 4.8d | 2016-11-08 | 2016-11-13 | PR-Z4-CW-CW-165-0050 | 290.6d | 0d |  |  | OK | 1.2.9.10 | PROC | PROC |
| PR-Z4-CW-CW-165-0070 |  | NMR 602 - LV & Grounding Cables |  | 4.8d | 2016-11-14 | 2016-11-19 | PR-Z4-CW-CW-165-0060 | 290.6d | 0d |  |  | OK | 1.2.9.10 | PROC | PROC |
| PR-Z4-CW-CW-165-0080 |  | Start of Material Delivery - MV Cables | milestone | 0d | 2017-01-02 | 2017-01-02 | PR-Z4-CW-CW-165-0070 FS+37.6d | 290.6d | 0d |  |  | OK | 1.2.9.10 | PROC | PROC |
| PR-Z4-CW-CW-165-0090 |  | Complete Material Delivery - MV Cables |  | 30d | 2017-01-02 | 2017-02-06 | PR-Z4-CW-CW-165-0080 | 290.6d | 0d | LV Cables [2761 Lm] | 122,722.02 | OK | 1.2.9.10 | PROC | PROC |
| PR-Z4-CW-CW-165-0100 |  | NMR 603 - MV Cables |  | 8d | 2017-02-06 | 2017-02-15 | PR-Z4-CW-CW-165-0090 | 290.6d | 208.4d |  |  | OK | 1.2.9.10 | PROC | PROC |
|  | 3 | **Sand for Backfilling** |  |  | 2016-09-07 | 2017-01-31 |  |  |  |  |  |  |  |  |  |
| PR-Z4-CW-CW-166-0010 |  | RFQ - Sand for Backfilling |  | 5.6d | 2016-09-07 | 2016-09-18 | PROC-GE-GE-GE-0010 FS+25d | 303.2d | 0d |  |  | OK | 1.2.9.10 | PROC | PROC |
| PR-Z4-CW-CW-166-0020 |  | Material Submittal - Sand for Backfilling |  | 8d | 2016-09-18 | 2016-09-27 | PR-Z4-CW-CW-166-0010 | 303.2d | 0d |  |  | OK | 1.2.9.10 | PROC | PROC |
| PR-Z4-CW-CW-166-0030 |  | Material Approval - Sand for Backfilling |  | 11.2d | 2016-09-27 | 2016-10-10 | PR-Z4-CW-CW-166-0020 | 303.2d | 0d |  |  | OK | 1.2.9.10 | PROC | PROC |
| PR-Z4-CW-CW-166-0040 |  | Technical Evaluation - Sand for Backfilling |  | 8d | 2016-10-11 | 2016-10-19 | PR-Z4-CW-CW-166-0030 | 303.2d | 0d |  |  | OK | 1.2.9.10 | PROC | PROC |
| PR-Z4-CW-CW-166-0050 |  | PO - Sand for Backfilling |  | 11.2d | 2016-10-20 | 2016-11-02 | PR-Z4-CW-CW-166-0040 | 303.2d | 0d |  |  | OK | 1.2.9.10 | PROC | PROC |
| PR-Z4-CW-CW-166-0060 |  | NMR 601 - Sand for Backfilling |  | 4.8d | 2016-11-02 | 2016-11-07 | PR-Z4-CW-CW-166-0050 | 303.2d | 0d |  |  | OK | 1.2.9.10 | PROC | PROC |
| PR-Z4-CW-CW-166-0070 |  | NMR 602 - Sand for Backfilling |  | 4.8d | 2016-11-08 | 2016-11-13 | PR-Z4-CW-CW-166-0060 | 303.2d | 0d |  |  | OK | 1.2.9.10 | PROC | PROC |
| PR-Z4-CW-CW-166-0080 |  | Start of Material Delivery - Sand for Backfilling | milestone | 0d | 2016-11-13 | 2016-11-13 | PR-Z4-CW-CW-166-0070 | 303.2d | 0d |  |  | OK | 1.2.9.10 | PROC | PROC |
| PR-Z4-CW-CW-166-0090 |  | Complete Material Delivery - Sand for Backfilling |  | 60d | 2016-11-13 | 2017-01-22 | PR-Z4-CW-CW-166-0080 | 303.2d | 0d | Sand for Backfilling [215.37 Cum] | 15,082.04 | OK | 1.2.9.10 | PROC | PROC |
| PR-Z4-CW-CW-166-0100 |  | NMR 603 - Sand for Backfilling |  | 8d | 2017-01-22 | 2017-01-31 | PR-Z4-CW-CW-166-0090 | 303.2d | 221d |  |  | OK | 1.2.9.10 | PROC | PROC |
|  | 4 | **Warning Tapes** |  |  | 2016-08-27 | 2016-12-29 |  |  |  |  |  |  |  |  |  |
| PR-Z4-CW-CW-167-0010 |  | RFQ - Warning Tapes |  | 12d | 2016-08-27 | 2016-09-10 | PROC-GE-GE-GE-0010 FS+15.2d | 331.8d | 0d |  |  | OK | 1.2.9.10 | PROC | PROC |
| PR-Z4-CW-CW-167-0020 |  | Material Submittal - Warning Tapes |  | 8d | 2016-09-10 | 2016-09-24 | PR-Z4-CW-CW-167-0010 | 331.8d | 0d |  |  | OK | 1.2.9.10 | PROC | PROC |
| PR-Z4-CW-CW-167-0030 |  | Material Approval - Warning Tapes |  | 11.2d | 2016-09-24 | 2016-10-06 | PR-Z4-CW-CW-167-0020 | 331.8d | 0d |  |  | OK | 1.2.9.10 | PROC | PROC |
| PR-Z4-CW-CW-167-0040 |  | Technical Evaluation - Warning Tapes |  | 8d | 2016-10-06 | 2016-10-16 | PR-Z4-CW-CW-167-0030 | 331.8d | 0d |  |  | OK | 1.2.9.10 | PROC | PROC |
| PR-Z4-CW-CW-167-0050 |  | PO - Warning Tapes |  | 11.2d | 2016-10-16 | 2016-10-29 | PR-Z4-CW-CW-167-0040 | 331.8d | 0d |  |  | OK | 1.2.9.10 | PROC | PROC |
| PR-Z4-CW-CW-167-0060 |  | NMR 601 - Warning Tapes |  | 4.8d | 2016-10-29 | 2016-11-03 | PR-Z4-CW-CW-167-0050 | 331.8d | 0d |  |  | OK | 1.2.9.10 | PROC | PROC |
| PR-Z4-CW-CW-167-0070 |  | NMR 602 - Warning Tapes |  | 4.8d | 2016-11-03 | 2016-11-09 | PR-Z4-CW-CW-167-0060 | 331.8d | 0d |  |  | OK | 1.2.9.10 | PROC | PROC |
| PR-Z4-CW-CW-167-0080 |  | Start of Material Delivery - Warning Tapes | milestone | 0d | 2016-11-15 | 2016-11-15 | PR-Z4-CW-CW-167-0070 FS+4.8d | 331.8d | 0d |  |  | OK | 1.2.9.10 | PROC | PROC |
| PR-Z4-CW-CW-167-0090 |  | Complete Material Delivery - Warning Tapes |  | 30d | 2016-11-15 | 2016-12-20 | PR-Z4-CW-CW-167-0080 | 331.8d | 0d | Warning Tapes [2393 Lm] | 8,728.03 | OK | 1.2.9.10 | PROC | PROC |
| PR-Z4-CW-CW-167-0100 |  | NMR 603 - Warning Tapes |  | 8d | 2016-12-20 | 2016-12-29 | PR-Z4-CW-CW-167-0090 | 331.8d | 249.6d |  |  | OK | 1.2.9.10 | PROC | PROC |

Notes:
- PR-Z4-CW-CW-165-0090: Expenses: (New Expense Item) 122722
- PR-Z4-CW-CW-166-0090: Expenses: (New Expense Item) 15082
- PR-Z4-CW-CW-167-0090: Expenses: (New Expense Item) 8728.03

| ID | WBS | Activity | Type | Duration | Start | Finish | Predecessors | Total float | Free float | Resources | Cost | Wajid | RPI_P2 - BOQ ITEMS | RPI_P2 - PROCUREMENT | RPI_P2 - PHASE |
| --- | --- | --- | --- | --- | --- | --- | --- | --- | --- | --- | --- | --- | --- | --- | --- |
|  | 5 | **Red Tiles** |  |  | 2016-08-27 | 2017-02-02 |  |  |  |  |  |  |  |  |  |
| PR-Z4-CW-CW-168-0010 |  | RFQ - Red Tiles |  | 12d | 2016-08-27 | 2016-09-10 | PROC-GE-GE-GE-0010 FS+15.2d | 301.8d | 0d |  |  | OK | 1.2.9.10 | PROC | PROC |
| PR-Z4-CW-CW-168-0020 |  | Material Submittal - Red Tiles |  | 8d | 2016-09-10 | 2016-09-24 | PR-Z4-CW-CW-168-0010 | 301.8d | 0d |  |  | OK | 1.2.9.10 | PROC | PROC |
| PR-Z4-CW-CW-168-0030 |  | Material Approval - Red Tiles |  | 11.2d | 2016-09-24 | 2016-10-06 | PR-Z4-CW-CW-168-0020 | 301.8d | 0d |  |  | OK | 1.2.9.10 | PROC | PROC |
| PR-Z4-CW-CW-168-0040 |  | Technical Evaluation - Red Tiles |  | 8d | 2016-10-06 | 2016-10-16 | PR-Z4-CW-CW-168-0030 | 301.8d | 0d |  |  | OK | 1.2.9.10 | PROC | PROC |
| PR-Z4-CW-CW-168-0050 |  | PO - Red Tiles |  | 11.2d | 2016-10-16 | 2016-10-29 | PR-Z4-CW-CW-168-0040 | 301.8d | 0d |  |  | OK | 1.2.9.10 | PROC | PROC |
| PR-Z4-CW-CW-168-0060 |  | NMR 601 - Red Tiles |  | 4.8d | 2016-10-29 | 2016-11-03 | PR-Z4-CW-CW-168-0050 | 301.8d | 0d |  |  | OK | 1.2.9.10 | PROC | PROC |
| PR-Z4-CW-CW-168-0070 |  | NMR 602 - Red Tiles |  | 4.8d | 2016-11-03 | 2016-11-09 | PR-Z4-CW-CW-168-0060 | 301.8d | 0d |  |  | OK | 1.2.9.10 | PROC | PROC |
| PR-Z4-CW-CW-168-0080 |  | Start of Material Delivery - Red Tiles | milestone | 0d | 2016-11-15 | 2016-11-15 | PR-Z4-CW-CW-168-0070 FS+4.8d | 301.8d | 0d |  |  | OK | 1.2.9.10 | PROC | PROC |
| PR-Z4-CW-CW-168-0090 |  | Complete Material Delivery - Red Tiles |  | 60d | 2016-11-15 | 2017-01-24 | PR-Z4-CW-CW-168-0080 | 301.8d | 0d | Red Tiles [11965 ea] | 43,640.15 | OK | 1.2.9.10 | PROC | PROC |
| PR-Z4-CW-CW-168-0100 |  | NMR 603 - Red Tiles |  | 8d | 2017-01-24 | 2017-02-02 | PR-Z4-CW-CW-168-0090 | 301.8d | 219.6d |  |  | OK | 1.2.9.10 | PROC | PROC |
|  | 2 | **Motor Control Gear** |  |  | 2016-08-28 | 2017-03-23 |  |  |  |  |  |  |  |  |  |
|  | 1 | **Lighting Fixtures (Lift Station)** |  |  | 2016-09-19 | 2017-03-01 |  |  |  |  |  |  |  |  |  |
| PR-Z4-CW-CW-169-0010 |  | RFQ - Lighting Fixtures (Lift Station) |  | 5.6d | 2016-09-19 | 2016-09-25 | PROC-GE-GE-GE-0010 FS+31.2d | 122d | 0d |  |  | OK | 1.2.9.20 | PROC | PROC |
| PR-Z4-CW-CW-169-0020 |  | Material Submittal - Lighting Fixtures (Lift Station) |  | 8d | 2016-09-26 | 2016-10-04 | PR-Z4-CW-CW-169-0010 | 122d | 0d |  |  | OK | 1.2.9.20 | PROC | PROC |
| PR-Z4-CW-CW-169-0030 |  | Material Approval - Lighting Fixtures (Lift Station) |  | 11.2d | 2016-10-05 | 2016-10-18 | PR-Z4-CW-CW-169-0020 | 122d | 0d |  |  | OK | 1.2.9.20 | PROC | PROC |
| PR-Z4-CW-CW-169-0040 |  | Technical Evaluation - Lighting Fixtures (Lift Station) |  | 8d | 2016-10-18 | 2016-10-27 | PR-Z4-CW-CW-169-0030 | 122d | 0d |  |  | OK | 1.2.9.20 | PROC | PROC |
| PR-Z4-CW-CW-169-0050 |  | PO - Lighting Fixtures (Lift Station) |  | 11.2d | 2016-10-27 | 2016-11-09 | PR-Z4-CW-CW-169-0040 | 122d | 0d |  |  | OK | 1.2.9.20 | PROC | PROC |
| PR-Z4-CW-CW-169-0060 |  | NMR 601 - Lighting Fixtures (Lift Station) |  | 12d | 2016-11-09 | 2016-11-23 | PR-Z4-CW-CW-169-0050 | 122d | 0d |  |  | OK | 1.2.9.20 | PROC | PROC |
| PR-Z4-CW-CW-169-0070 |  | NMR 602 - Lighting Fixtures (Lift Station) |  | 12d | 2016-11-23 | 2016-12-07 | PR-Z4-CW-CW-169-0060 | 122d | 0d |  |  | OK | 1.2.9.20 | PROC | PROC |
| PR-Z4-CW-CW-169-0080 |  | Start of Material Delivery - Lighting Fixtures (Lift Station) | milestone | 0d | 2017-02-06 | 2017-02-06 | PR-Z4-CW-CW-169-0070 FS+52d | 122d | 0d |  |  | OK | 1.2.9.20 | PROC | PROC |
| PR-Z4-CW-CW-169-0090 |  | Complete Material Delivery - Lighting Fixtures (Lift Station) |  | 12d | 2017-02-06 | 2017-02-20 | PR-Z4-CW-CW-169-0080 | 278.6d | 0d | Ligting Fixtures [14 ea] | 11,632.33 | OK | 1.2.9.20 | PROC | PROC |
| PR-Z4-CW-CW-169-0100 |  | NMR 603 - Lighting Fixtures (Lift Station) |  | 8d | 2017-02-20 | 2017-03-01 | PR-Z4-CW-CW-169-0090 | 278.6d | 196.4d |  |  | OK | 1.2.9.20 | PROC | PROC |
|  | 2 | **Rigid Conduits PVC Coated (Lift Station)** |  |  | 2016-10-05 | 2017-01-07 |  |  |  |  |  |  |  |  |  |
| PR-Z4-CW-CW-170-0010 |  | RFQ - Rigid Conduits PVC Coated (Lift Station) |  | 12d | 2016-10-05 | 2016-10-19 | PROC-GE-GE-GE-0010 FS+45d | 324.8d | 0d |  |  | OK | 1.2.9.20 | PROC | PROC |
| PR-Z4-CW-CW-170-0020 |  | Material Submittal - Rigid Conduits PVC Coated (Lift Station) |  | 8d | 2016-10-19 | 2016-10-29 | PR-Z4-CW-CW-170-0010 | 324.8d | 0d |  |  | OK | 1.2.9.20 | PROC | PROC |
| PR-Z4-CW-CW-170-0030 |  | Material Approval - Rigid Conduits PVC Coated (Lift Station) |  | 11.2d | 2016-10-29 | 2016-11-10 | PR-Z4-CW-CW-170-0020 | 324.8d | 0d |  |  | OK | 1.2.9.20 | PROC | PROC |
| PR-Z4-CW-CW-170-0040 |  | Technical Evaluation - Rigid Conduits PVC Coated (Lift Station) |  | 8d | 2016-11-10 | 2016-11-20 | PR-Z4-CW-CW-170-0030 | 324.8d | 0d |  |  | OK | 1.2.9.20 | PROC | PROC |
| PR-Z4-CW-CW-170-0050 |  | PO - Rigid Conduits PVC Coated (Lift Station) |  | 11.2d | 2016-11-20 | 2016-12-03 | PR-Z4-CW-CW-170-0040 | 324.8d | 0d |  |  | OK | 1.2.9.20 | PROC | PROC |
| PR-Z4-CW-CW-170-0060 |  | NMR 601 - Rigid Conduits PVC Coated (Lift Station) |  | 4.8d | 2016-12-03 | 2016-12-08 | PR-Z4-CW-CW-170-0050 | 324.8d | 0d |  |  | OK | 1.2.9.20 | PROC | PROC |
| PR-Z4-CW-CW-170-0070 |  | NMR 602 - Rigid Conduits PVC Coated (Lift Station) |  | 4.8d | 2016-12-08 | 2016-12-14 | PR-Z4-CW-CW-170-0060 | 324.8d | 0d |  |  | OK | 1.2.9.20 | PROC | PROC |
| PR-Z4-CW-CW-170-0080 |  | Start of Material Delivery - Rigid Conduits PVC Coated (Lift Station) | milestone | 0d | 2016-12-14 | 2016-12-14 | PR-Z4-CW-CW-170-0070 | 324.8d | 0d |  |  | OK | 1.2.9.20 | PROC | PROC |
| PR-Z4-CW-CW-170-0090 |  | Complete Material Delivery - Rigid Conduits PVC Coated (Lift Station) |  | 12d | 2016-12-14 | 2016-12-28 | PR-Z4-CW-CW-170-0080 | 324.8d | 0d | PVC Coated Conduits including Accessories [377 Lm] | 18,393.26 | OK | 1.2.9.20 | PROC | PROC |
| PR-Z4-CW-CW-170-0100 |  | NMR 603 - Rigid Conduits PVC Coated (Lift Station) |  | 8d | 2016-12-28 | 2017-01-07 | PR-Z4-CW-CW-170-0090 | 324.8d | 242.6d |  |  | OK | 1.2.9.20 | PROC | PROC |

Notes:
- PR-Z4-CW-CW-168-0090: Expenses: (New Expense Item) 43640.2
- PR-Z4-CW-CW-169-0090: Expenses: (New Expense Item) 11632.3
- PR-Z4-CW-CW-170-0090: Expenses: (New Expense Item) 18393.3

| ID | WBS | Activity | Type | Duration | Start | Finish | Predecessors | Total float | Free float | Resources | Cost | Wajid | RPI_P2 - BOQ ITEMS | RPI_P2 - PROCUREMENT | RPI_P2 - PHASE |
| --- | --- | --- | --- | --- | --- | --- | --- | --- | --- | --- | --- | --- | --- | --- | --- |
|  | 3 | **LV Cables & Grounding Cables and Accessories** |  |  | 2016-08-28 | 2017-01-04 |  |  |  |  |  |  |  |  |  |
| PR-Z4-CW-CW-171-0010 |  | RFQ - LV Cables & Grounding Cables and Accessories |  | 5.6d | 2016-08-28 | 2016-09-03 | PROC-GE-GE-GE-0010 FS+16d | 326.6d | 0d |  |  | OK | 1.2.9.20 | PROC | PROC |
| PR-Z4-CW-CW-171-0020 |  | Material Submittal - LV Cables & Grounding Cables and Accessories |  | 8d | 2016-09-03 | 2016-09-17 | PR-Z4-CW-CW-171-0010 | 326.6d | 0d |  |  | OK | 1.2.9.20 | PROC | PROC |
| PR-Z4-CW-CW-171-0030 |  | Material Approval - LV Cables & Grounding Cables and Accessories |  | 11.2d | 2016-09-17 | 2016-09-29 | PR-Z4-CW-CW-171-0020 | 326.6d | 0d |  |  | OK | 1.2.9.20 | PROC | PROC |
| PR-Z4-CW-CW-171-0040 |  | Technical Evaluation - LV Cables & Grounding Cables and Accessories |  | 8d | 2016-10-01 | 2016-10-09 | PR-Z4-CW-CW-171-0030 | 326.6d | 0d |  |  | OK | 1.2.9.20 | PROC | PROC |
| PR-Z4-CW-CW-171-0050 |  | PO - LV Cables & Grounding Cables and Accessories |  | 11.2d | 2016-10-10 | 2016-10-23 | PR-Z4-CW-CW-171-0040 | 326.6d | 0d |  |  | OK | 1.2.9.20 | PROC | PROC |
| PR-Z4-CW-CW-171-0060 |  | NMR 601 - LV Cables & Grounding Cables and Accessories |  | 4.8d | 2016-10-23 | 2016-10-27 | PR-Z4-CW-CW-171-0050 | 326.6d | 0d |  |  | OK | 1.2.9.20 | PROC | PROC |
| PR-Z4-CW-CW-171-0070 |  | NMR 602 - LV Cables & Grounding Cables and Accessories |  | 4.8d | 2016-10-29 | 2016-11-02 | PR-Z4-CW-CW-171-0060 | 326.6d | 0d |  |  | OK | 1.2.9.20 | PROC | PROC |
| PR-Z4-CW-CW-171-0080 |  | Start of Material Delivery - LV Cables & Grounding Cables and Accessories | milestone | 0d | 2016-12-12 | 2016-12-12 | PR-Z4-CW-CW-171-0070 FS+33.6d | 326.6d | 0d |  |  | OK | 1.2.9.20 | PROC | PROC |
| PR-Z4-CW-CW-171-0090 |  | Complete Material Delivery - LV Cables & Grounding Cables and Accessories |  | 12d | 2016-12-12 | 2016-12-26 | PR-Z4-CW-CW-171-0080 | 326.6d | 0d | Ground Cable and Accessories [1 Lm]; LV Cables [1923 Lm] | 33,458.36 | OK | 1.2.9.20 | PROC | PROC |
| PR-Z4-CW-CW-171-0100 |  | NMR 603 - LV Cables & Grounding Cables and Accessories |  | 8d | 2016-12-26 | 2017-01-04 | PR-Z4-CW-CW-171-0090 | 326.6d | 244.4d |  |  | OK | 1.2.9.20 | PROC | PROC |
|  | 4 | **Wiring Devices, Disconnect Switches** |  |  | 2016-09-28 | 2017-03-23 |  |  |  |  |  |  |  |  |  |
| PR-Z4-CW-CW-172-0010 |  | RFQ - Wiring Devices, Disconnect Switches |  | 6d | 2016-09-28 | 2016-10-05 | PROC-GE-GE-GE-0010 FS+39.2d | 45.6d | 0d |  |  | OK | 1.2.9.20 | PROC | PROC |
| PR-Z4-CW-CW-172-0020 |  | Material Submittal - Wiring Devices, Disconnect Switches |  | 6d | 2016-10-05 | 2016-10-12 | PR-Z4-CW-CW-172-0010 | 45.6d | 0d |  |  | OK | 1.2.9.20 | PROC | PROC |
| PR-Z4-CW-CW-172-0030 |  | Material Approval - Wiring Devices, Disconnect Switches |  | 11d | 2016-10-12 | 2016-10-25 | PR-Z4-CW-CW-172-0020 | 45.6d | 0d |  |  | OK | 1.2.9.20 | PROC | PROC |
| PR-Z4-CW-CW-172-0040 |  | Technical Evaluation - Wiring Devices, Disconnect Switches |  | 6d | 2016-10-25 | 2016-11-01 | PR-Z4-CW-CW-172-0030 | 45.6d | 0d |  |  | OK | 1.2.9.20 | PROC | PROC |
| PR-Z4-CW-CW-172-0050 |  | PO - Wiring Devices, Disconnect Switches |  | 12d | 2016-11-01 | 2016-11-15 | PR-Z4-CW-CW-172-0040 | 45.6d | 0d |  |  | OK | 1.2.9.20 | PROC | PROC |
| PR-Z4-CW-CW-172-0060 |  | NMR 601 - Wiring Devices, Disconnect Switches |  | 6d | 2016-11-15 | 2016-11-22 | PR-Z4-CW-CW-172-0050 | 45.6d | 0d |  |  | OK | 1.2.9.20 | PROC | PROC |
| PR-Z4-CW-CW-172-0070 |  | NMR 602 - Wiring Devices, Disconnect Switches |  | 6d | 2016-11-22 | 2016-11-29 | PR-Z4-CW-CW-172-0060 | 45.6d | 0d |  |  | OK | 1.2.9.20 | PROC | PROC |
| PR-Z4-CW-CW-172-0080 |  | Start of Material Delivery - Wiring Devices, Disconnect Switches | milestone | 0d | 2017-02-28 | 2017-02-28 | PR-Z4-CW-CW-172-0070 FS+78.4d | 45.6d | 0d |  |  | OK | 1.2.9.20 | PROC | PROC |
| PR-Z4-CW-CW-172-0090 |  | Complete Material Delivery - Wiring Devices, Disconnect Switches |  | 12d | 2017-02-28 | 2017-03-14 | PR-Z4-CW-CW-172-0080 | 259.2d | 0d | Wiring Devices [11 ea] | 7,192.48 | OK | 1.2.9.20 | PROC | PROC |
| PR-Z4-CW-CW-172-0100 |  | NMR 603 - Wiring Devices, Disconnect Switches |  | 8d | 2017-03-14 | 2017-03-23 | PR-Z4-CW-CW-172-0090 | 259.2d | 177d |  |  | OK | 1.2.9.20 | PROC | PROC |
|  | 5 | **MCC Panel (LS-9)** |  |  | 2016-08-31 | 2017-03-02 |  |  |  |  |  |  |  |  |  |
| PR-Z4-CW-CW-173-0010 |  | RFQ - MCC Panel (LS-9) |  | 12d | 2016-08-31 | 2016-09-19 | PROC-GE-GE-GE-0010 FS+19.2d | 149.2d | 0d |  |  | OK | 1.2.9.20 | PROC | PROC |
| PR-Z4-CW-CW-173-0020 |  | Material Submittal - MCC Panel (LS-9) |  | 8d | 2016-09-19 | 2016-09-28 | PR-Z4-CW-CW-173-0010 | 149.2d | 0d |  |  | OK | 1.2.9.20 | PROC | PROC |
| PR-Z4-CW-CW-173-0030 |  | Material Approval - MCC Panel (LS-9) |  | 11.2d | 2016-09-28 | 2016-10-11 | PR-Z4-CW-CW-173-0020 | 149.2d | 0d |  |  | OK | 1.2.9.20 | PROC | PROC |
| PR-Z4-CW-CW-173-0040 |  | Technical Evaluation - MCC Panel (LS-9) |  | 8d | 2016-10-11 | 2016-10-20 | PR-Z4-CW-CW-173-0030 | 149.2d | 0d |  |  | OK | 1.2.9.20 | PROC | PROC |
| PR-Z4-CW-CW-173-0050 |  | PO - MCC Panel (LS-9) |  | 11.2d | 2016-10-20 | 2016-11-02 | PR-Z4-CW-CW-173-0040 | 149.2d | 0d |  |  | OK | 1.2.9.20 | PROC | PROC |
| PR-Z4-CW-CW-173-0060 |  | NMR 601 - MCC Panel (LS-9) |  | 12d | 2016-11-02 | 2016-11-16 | PR-Z4-CW-CW-173-0050 | 149.2d | 0d |  |  | OK | 1.2.9.20 | PROC | PROC |
| PR-Z4-CW-CW-173-0070 |  | NMR 602 - MCC Panel (LS-9) |  | 12d | 2016-11-16 | 2016-11-30 | PR-Z4-CW-CW-173-0060 | 149.2d | 0d |  |  | OK | 1.2.9.20 | PROC | PROC |
| PR-Z4-CW-CW-173-0080 |  | Start of Material Delivery - MCC Panel (LS-9) | milestone | 0d | 2017-02-07 | 2017-02-07 | PR-Z4-CW-CW-173-0070 FS+58.4d | 149.2d | 0d |  |  | OK | 1.2.9.20 | PROC | PROC |
| PR-Z4-CW-CW-173-0090 |  | Complete Material Delivery - MCC Panel (LS-9) |  | 12d | 2017-02-07 | 2017-02-21 | PR-Z4-CW-CW-173-0080 | 277.8d | 0d | MCC Panels [1 ea] | 224,764.92 | OK | 1.2.9.20 | PROC | PROC |
| PR-Z4-CW-CW-173-0100 |  | NMR 603 - MCC Panel (LS-9) |  | 8d | 2017-02-21 | 2017-03-02 | PR-Z4-CW-CW-173-0090 | 277.8d | 195.6d |  |  | OK | 1.2.9.20 | PROC | PROC |

Notes:
- PR-Z4-CW-CW-171-0090: Expenses: (New Expense Item) 33458.4
- PR-Z4-CW-CW-172-0090: Expenses: (New Expense Item) 7192.48
- PR-Z4-CW-CW-173-0090: Expenses: (New Expense Item) 224765

| ID | WBS | Activity | Type | Duration | Start | Finish | Predecessors | Total float | Free float | Resources | Cost | Wajid | RPI_P2 - BOQ ITEMS | RPI_P2 - PROCUREMENT | RPI_P2 - PHASE |
| --- | --- | --- | --- | --- | --- | --- | --- | --- | --- | --- | --- | --- | --- | --- | --- |
|  | 6 | **Sand for Backfillig** |  |  | 2016-09-19 | 2016-12-04 |  |  |  |  |  |  |  |  |  |
| PR-Z4-CW-CW-173-0110 |  | RFQ - Sand for Backfilling |  | 5.6d | 2016-09-19 | 2016-09-25 | PR-Z4-CW-CW-173-0010 | 336.2d | 0d |  |  | OK | 1.2.9.20 | PROC | PROC |
| PR-Z4-CW-CW-173-0120 |  | Material Submittal - Sand for Backfilling |  | 8d | 2016-09-26 | 2016-10-04 | PR-Z4-CW-CW-173-0110 | 353d | 0d |  |  | OK | 1.2.9.20 | PROC | PROC |
| PR-Z4-CW-CW-173-0130 |  | Material Approval - Sand for Backfilling |  | 11.2d | 2016-10-05 | 2016-10-18 | PR-Z4-CW-CW-173-0120 | 353d | 0d |  |  | OK | 1.2.9.20 | PROC | PROC |
| PR-Z4-CW-CW-173-0140 |  | Technical Evaluation - Sand for Backfilling |  | 8d | 2016-10-18 | 2016-10-27 | PR-Z4-CW-CW-173-0130 | 353d | 0d |  |  | OK | 1.2.9.20 | PROC | PROC |
| PR-Z4-CW-CW-173-0150 |  | PO - Sand for Backfilling |  | 11.2d | 2016-10-27 | 2016-11-09 | PR-Z4-CW-CW-173-0140 | 353d | 0d |  |  | OK | 1.2.9.20 | PROC | PROC |
| PR-Z4-CW-CW-173-0160 |  | NMR 601 - Sand for Backfilling |  | 4.8d | 2016-11-09 | 2016-11-15 | PR-Z4-CW-CW-173-0150 | 353d | 0d |  |  | OK | 1.2.9.20 | PROC | PROC |
| PR-Z4-CW-CW-173-0170 |  | NMR 602 - Sand for Backfilling |  | 4.8d | 2016-11-15 | 2016-11-20 | PR-Z4-CW-CW-173-0160 | 353d | 0d |  |  | OK | 1.2.9.20 | PROC | PROC |
| PR-Z4-CW-CW-173-0180 |  | Start of Material Delivery - Sand for Backfilling | milestone | 0d | 2016-11-21 | 2016-11-21 | PR-Z4-CW-CW-173-0170 | 353d | 0d |  |  | OK | 1.2.9.20 | PROC | PROC |
| PR-Z4-CW-CW-173-0190 |  | Complete Material Delivery - Sand for Backfilling |  | 12d | 2016-11-21 | 2016-12-04 | PR-Z4-CW-CW-173-0180 | 353d | 270.8d | Sand for Backfilling [20.4 Cum] | 1,467.27 | OK | 1.2.9.20 | PROC | PROC |
|  | 7 | **Warning Tapes** |  |  | 2016-09-26 | 2016-12-11 |  |  |  |  |  |  |  |  |  |
| PR-Z4-CW-CW-173-0210 |  | RFQ - Warning Tapes |  | 5.6d | 2016-09-26 | 2016-10-02 | PR-Z4-CW-CW-173-0110 | 336.2d | 0d |  |  | OK | 1.2.9.20 | PROC | PROC |
| PR-Z4-CW-CW-173-0220 |  | Material Submittal - Warning Tapes |  | 8d | 2016-10-02 | 2016-10-11 | PR-Z4-CW-CW-173-0210 | 347.4d | 0d |  |  | OK | 1.2.9.20 | PROC | PROC |
| PR-Z4-CW-CW-173-0230 |  | Material Approval - Warning Tapes |  | 11.2d | 2016-10-11 | 2016-10-24 | PR-Z4-CW-CW-173-0220 | 347.4d | 0d |  |  | OK | 1.2.9.20 | PROC | PROC |
| PR-Z4-CW-CW-173-0240 |  | Technical Evaluation - Warning Tapes |  | 8d | 2016-10-24 | 2016-11-02 | PR-Z4-CW-CW-173-0230 | 347.4d | 0d |  |  | OK | 1.2.9.20 | PROC | PROC |
| PR-Z4-CW-CW-173-0250 |  | PO - Warning Tapes |  | 11.2d | 2016-11-02 | 2016-11-15 | PR-Z4-CW-CW-173-0240 | 347.4d | 0d |  |  | OK | 1.2.9.20 | PROC | PROC |
| PR-Z4-CW-CW-173-0260 |  | NMR 601 - Warning Tapes |  | 4.8d | 2016-11-16 | 2016-11-21 | PR-Z4-CW-CW-173-0250 | 347.4d | 0d |  |  | OK | 1.2.9.20 | PROC | PROC |
| PR-Z4-CW-CW-173-0270 |  | NMR 602 - Warning Tapes |  | 4.8d | 2016-11-21 | 2016-11-27 | PR-Z4-CW-CW-173-0260 | 347.4d | 0d |  |  | OK | 1.2.9.20 | PROC | PROC |
| PR-Z4-CW-CW-173-0280 |  | Start of Material Delivery - Warning Tapes | milestone | 0d | 2016-11-27 | 2016-11-27 | PR-Z4-CW-CW-173-0270 | 347.4d | 0d |  |  | OK | 1.2.9.20 | PROC | PROC |
| PR-Z4-CW-CW-173-0290 |  | Complete Material Delivery - Warning Tapes |  | 12d | 2016-11-27 | 2016-12-11 | PR-Z4-CW-CW-173-0280 | 347.4d | 265.2d | Warning Tapes [93 Lm] | 348.39 | OK | 1.2.9.20 | PROC | PROC |
|  | 8 | **Cable Marker** |  |  | 2016-10-02 | 2016-12-18 |  |  |  |  |  |  |  |  |  |
| PR-Z4-CW-CW-173-0310 |  | RFQ - Cable Marker |  | 5.6d | 2016-10-02 | 2016-10-09 | PR-Z4-CW-CW-173-0210 | 336.2d | 0d |  |  | OK | 1.2.9.20 | PROC | PROC |
| PR-Z4-CW-CW-173-0320 |  | Material Submittal - Cable Marker |  | 8d | 2016-10-09 | 2016-10-18 | PR-Z4-CW-CW-173-0310 | 341.8d | 0d |  |  | OK | 1.2.9.20 | PROC | PROC |
| PR-Z4-CW-CW-173-0330 |  | Material Approval - Cable Marker |  | 11.2d | 2016-10-18 | 2016-10-31 | PR-Z4-CW-CW-173-0320 | 341.8d | 0d |  |  | OK | 1.2.9.20 | PROC | PROC |
| PR-Z4-CW-CW-173-0340 |  | Technical Evaluation - Cable Marker |  | 8d | 2016-10-31 | 2016-11-09 | PR-Z4-CW-CW-173-0330 | 341.8d | 0d |  |  | OK | 1.2.9.20 | PROC | PROC |
| PR-Z4-CW-CW-173-0350 |  | PO - Cable Marker |  | 11.2d | 2016-11-09 | 2016-11-22 | PR-Z4-CW-CW-173-0340 | 341.8d | 0d |  |  | OK | 1.2.9.20 | PROC | PROC |
| PR-Z4-CW-CW-173-0360 |  | NMR 601 - Cable Marker |  | 4.8d | 2016-11-22 | 2016-11-28 | PR-Z4-CW-CW-173-0350 | 341.8d | 0d |  |  | OK | 1.2.9.20 | PROC | PROC |
| PR-Z4-CW-CW-173-0370 |  | NMR 602 - Cable Marker |  | 4.8d | 2016-11-28 | 2016-12-04 | PR-Z4-CW-CW-173-0360 | 341.8d | 0d |  |  | OK | 1.2.9.20 | PROC | PROC |
| PR-Z4-CW-CW-173-0380 |  | Start of Material Delivery - Cable Marker | milestone | 0d | 2016-12-04 | 2016-12-04 | PR-Z4-CW-CW-173-0370 | 341.8d | 0d |  |  | OK | 1.2.9.20 | PROC | PROC |
| PR-Z4-CW-CW-173-0390 |  | Complete Material Delivery - Cable Marker |  | 12d | 2016-12-04 | 2016-12-18 | PR-Z4-CW-CW-173-0380 | 341.8d | 259.6d | Cable Markers [4 ea] | 1,348.59 | OK | 1.2.9.20 | PROC | PROC |

Notes:
- PR-Z4-CW-CW-173-0190: Expenses: (New Expense Item) 1467.27
- PR-Z4-CW-CW-173-0290: Expenses: (New Expense Item) 348.39
- PR-Z4-CW-CW-173-0390: Expenses: (New Expense Item) 1348.59

| ID | WBS | Activity | Type | Duration | Start | Finish | Predecessors | Total float | Free float | Resources | Cost | Wajid | RPI_P2 - BOQ ITEMS | RPI_P2 - PROCUREMENT | RPI_P2 - PHASE |
| --- | --- | --- | --- | --- | --- | --- | --- | --- | --- | --- | --- | --- | --- | --- | --- |
|  | 9 | **Red Tiles** |  |  | 2016-10-09 | 2016-12-24 |  |  |  |  |  |  |  |  |  |
| PR-Z4-CW-CW-173-0410 |  | RFQ - Red Tiles |  | 5.6d | 2016-10-09 | 2016-10-15 | PR-Z4-CW-CW-173-0310 | 336.2d | 0d |  |  | OK | 1.2.9.20 | PROC | PROC |
| PR-Z4-CW-CW-173-0420 |  | Material Submittal - Red Tiles |  | 8d | 2016-10-15 | 2016-10-24 | PR-Z4-CW-CW-173-0410 | 336.2d | 0d |  |  | OK | 1.2.9.20 | PROC | PROC |
| PR-Z4-CW-CW-173-0430 |  | Material Approval - Red Tiles |  | 11.2d | 2016-10-24 | 2016-11-06 | PR-Z4-CW-CW-173-0420 | 336.2d | 0d |  |  | OK | 1.2.9.20 | PROC | PROC |
| PR-Z4-CW-CW-173-0440 |  | Technical Evaluation - Red Tiles |  | 8d | 2016-11-07 | 2016-11-15 | PR-Z4-CW-CW-173-0430 | 336.2d | 0d |  |  | OK | 1.2.9.20 | PROC | PROC |
| PR-Z4-CW-CW-173-0450 |  | PO - Red Tiles |  | 11.2d | 2016-11-16 | 2016-11-29 | PR-Z4-CW-CW-173-0440 | 336.2d | 0d |  |  | OK | 1.2.9.20 | PROC | PROC |
| PR-Z4-CW-CW-173-0460 |  | NMR 601 - Red Tiles |  | 4.8d | 2016-11-29 | 2016-12-04 | PR-Z4-CW-CW-173-0450 | 336.2d | 0d |  |  | OK | 1.2.9.20 | PROC | PROC |
| PR-Z4-CW-CW-173-0470 |  | NMR 602 - Red Tiles |  | 4.8d | 2016-12-05 | 2016-12-10 | PR-Z4-CW-CW-173-0460 | 336.2d | 0d |  |  | OK | 1.2.9.20 | PROC | PROC |
| PR-Z4-CW-CW-173-0480 |  | Start of Material Delivery - Red Tiles | milestone | 0d | 2016-12-10 | 2016-12-10 | PR-Z4-CW-CW-173-0470 | 336.2d | 0d |  |  | OK | 1.2.9.20 | PROC | PROC |
| PR-Z4-CW-CW-173-0490 |  | Complete Material Delivery - Red Tiles |  | 12d | 2016-12-10 | 2016-12-24 | PR-Z4-CW-CW-173-0480 | 336.2d | 254d | Red Tiles [445 ea] | 1,667.01 | OK | 1.2.9.20 | PROC | PROC |
|  | 10 | **Instrumentation Materials (LS-9)** |  |  | 2016-09-07 | 2017-03-01 |  |  |  |  |  |  |  |  |  |
| PR-Z4-CW-CW-174-0010 |  | RFQ - Instrumentation Materials (LS-9) |  | 5.6d | 2016-09-07 | 2016-09-18 | PR-Z4-CW-CW-173-0010 SS+6d | 278.2d | 0d |  |  | OK | 1.2.9.20 | PROC | PROC |
| PR-Z4-CW-CW-174-0020 |  | Material Submittal - Instrumentation Materials (LS-9) |  | 8d | 2016-09-19 | 2016-09-27 | PR-Z4-CW-CW-174-0010 | 278.2d | 0d |  |  | OK | 1.2.9.20 | PROC | PROC |
| PR-Z4-CW-CW-174-0030 |  | Material Approval - Instrumentation Materials (LS-9) |  | 11.2d | 2016-09-28 | 2016-10-11 | PR-Z4-CW-CW-174-0020 | 278.2d | 0d |  |  | OK | 1.2.9.20 | PROC | PROC |
| PR-Z4-CW-CW-174-0040 |  | Technical Evaluation - Instrumentation Materials (LS-9) |  | 8d | 2016-10-11 | 2016-10-20 | PR-Z4-CW-CW-174-0030 | 278.2d | 0d |  |  | OK | 1.2.9.20 | PROC | PROC |
| PR-Z4-CW-CW-174-0050 |  | PO - Instrumentation Materials (LS-9) |  | 11.2d | 2016-10-20 | 2016-11-02 | PR-Z4-CW-CW-174-0040 | 278.2d | 0d |  |  | OK | 1.2.9.20 | PROC | PROC |
| PR-Z4-CW-CW-174-0060 |  | NMR 601 - Instrumentation Materials (LS-9) |  | 12d | 2016-11-02 | 2016-11-16 | PR-Z4-CW-CW-174-0050 | 278.2d | 0d |  |  | OK | 1.2.9.20 | PROC | PROC |
| PR-Z4-CW-CW-174-0070 |  | NMR 602 - Instrumentation Materials (LS-9) |  | 12d | 2016-11-16 | 2016-11-30 | PR-Z4-CW-CW-174-0060 | 278.2d | 0d |  |  | OK | 1.2.9.20 | PROC | PROC |
| PR-Z4-CW-CW-174-0080 |  | Start of Material Delivery - Instrumentation Materials (LS-9) | milestone | 0d | 2017-02-06 | 2017-02-06 | PR-Z4-CW-CW-174-0070 FS+58.4d | 278.2d | 0d |  |  | OK | 1.2.9.20 | PROC | PROC |
| PR-Z4-CW-CW-174-0090 |  | Complete Material Delivery - Instrumentation Materials (LS-9) |  | 12d | 2017-02-06 | 2017-02-20 | PR-Z4-CW-CW-174-0080 | 278.2d | 0d | Instrumentation Materials [1 LS] | 134,858.95 | OK | 1.2.9.20 | PROC | PROC |
| PR-Z4-CW-CW-174-0100 |  | NMR 603 - Instrumentation Materials (LS-9) |  | 8d | 2017-02-20 | 2017-03-01 | PR-Z4-CW-CW-174-0090 | 278.2d | 196d |  |  | OK | 1.2.9.20 | PROC | PROC |
|  | 3 | **Miscellaneous Electrical Items** |  |  | 2016-08-28 | 2017-02-12 |  |  |  |  |  |  |  |  |  |
|  | 1 | **MV Cables Termination Kits & Glanding Accessories** |  |  | 2016-09-03 | 2017-02-12 |  |  |  |  |  |  |  |  |  |
| PR-Z4-EW-EL-179-0010 |  | RFQ - MV Cables Termination Kits & Glanding Accessories |  | 12d | 2016-09-03 | 2016-09-21 | PROC-GE-GE-GE-0010 FS+21d | 293.6d | 0d |  |  | OK | 1.2.9.30 | PROC | PROC |
| PR-Z4-EW-EL-179-0020 |  | Material Submittal - MV Cables Termination Kits & Glanding Accessories |  | 8d | 2016-09-21 | 2016-10-01 | PR-Z4-EW-EL-179-0010 | 293.6d | 0d |  |  | OK | 1.2.9.30 | PROC | PROC |
| PR-Z4-EW-EL-179-0030 |  | Material Approval - MV Cables Termination Kits & Glanding Accessories |  | 11.2d | 2016-10-01 | 2016-10-13 | PR-Z4-EW-EL-179-0020 | 293.6d | 0d |  |  | OK | 1.2.9.30 | PROC | PROC |
| PR-Z4-EW-EL-179-0040 |  | Technical Evaluation - MV Cables Termination Kits & Glanding Accessories |  | 8d | 2016-10-13 | 2016-10-23 | PR-Z4-EW-EL-179-0030 | 293.6d | 0d |  |  | OK | 1.2.9.30 | PROC | PROC |
| PR-Z4-EW-EL-179-0050 |  | PO - MV Cables Termination Kits & Glanding Accessories |  | 11.2d | 2016-10-23 | 2016-11-05 | PR-Z4-EW-EL-179-0040 | 293.6d | 0d |  |  | OK | 1.2.9.30 | PROC | PROC |
| PR-Z4-EW-EL-179-0060 |  | NMR 601 - MV Cables Termination Kits & Glanding Accessories |  | 4.8d | 2016-11-05 | 2016-11-10 | PR-Z4-EW-EL-179-0050 | 293.6d | 0d |  |  | OK | 1.2.9.30 | PROC | PROC |
| PR-Z4-EW-EL-179-0070 |  | NMR 602 - MV Cables Termination Kits & Glanding Accessories |  | 4.8d | 2016-11-10 | 2016-11-16 | PR-Z4-EW-EL-179-0060 | 293.6d | 0d |  |  | OK | 1.2.9.30 | PROC | PROC |
| PR-Z4-EW-EL-179-0080 |  | Start of Material Delivery - MV Cables Termination Kits & Glanding Accessories | milestone | 0d | 2017-01-05 | 2017-01-05 | PR-Z4-EW-EL-179-0070 FS+43.2d | 293.6d | 0d |  |  | OK | 1.2.9.30 | PROC | PROC |
| PR-Z4-EW-EL-179-0090 |  | Complete Material Delivery - MV Cables Termination Kits & Glanding Accessories |  | 24d | 2017-01-05 | 2017-02-02 | PR-Z4-EW-EL-179-0080 | 293.6d | 0d | MV Cables Splicing & Repairing Kits [1 ea] | 41,126.16 | OK | 1.2.9.30 | PROC | PROC |
| PR-Z4-EW-EL-179-0100 |  | NMR 603 - MV Cables Termination Kits & Glanding Accessories |  | 8d | 2017-02-02 | 2017-02-12 | PR-Z4-EW-EL-179-0090 | 293.6d | 211.4d |  |  | OK | 1.2.9.30 | PROC | PROC |

Notes:
- PR-Z4-CW-CW-173-0490: Expenses: (New Expense Item) 1667.01
- PR-Z4-CW-CW-174-0090: Expenses: (New Expense Item) 134859
- PR-Z4-EW-EL-179-0090: Expenses: (New Expense Item) 41126.2

| ID | WBS | Activity | Type | Duration | Start | Finish | Predecessors | Total float | Free float | Resources | Cost | Wajid | RPI_P2 - BOQ ITEMS | RPI_P2 - PROCUREMENT | RPI_P2 - PHASE |
| --- | --- | --- | --- | --- | --- | --- | --- | --- | --- | --- | --- | --- | --- | --- | --- |
|  | 2 | **Grounding Rod & Accessories** |  |  | 2016-08-28 | 2017-01-11 |  |  |  |  |  |  |  |  |  |
| PR-Z4-EW-EL-179-100 |  | RFQ - Grounding Rod & Accessories |  | 12d | 2016-08-28 | 2016-09-15 | PROC-GE-GE-GE-0010 FS+16d | 320.2d | 0d |  |  | OK | 1.2.9.30 | PROC | PROC |
| PR-Z4-EW-EL-179-110 |  | Material Submittal - Grounding Rod & Accessories |  | 8d | 2016-09-15 | 2016-09-25 | PR-Z4-EW-EL-179-100 | 320.2d | 0d |  |  | OK | 1.2.9.30 | PROC | PROC |
| PR-Z4-EW-EL-179-120 |  | Material Approval - Grounding Rod & Accessories |  | 11.2d | 2016-09-25 | 2016-10-08 | PR-Z4-EW-EL-179-110 | 320.2d | 0d |  |  | OK | 1.2.9.30 | PROC | PROC |
| PR-Z4-EW-EL-179-130 |  | Technical Evaluation - Grounding Rod & Accessories |  | 8d | 2016-10-08 | 2016-10-17 | PR-Z4-EW-EL-179-120 | 320.2d | 0d |  |  | OK | 1.2.9.30 | PROC | PROC |
| PR-Z4-EW-EL-179-140 |  | PO - Grounding Rod & Accessories |  | 11.2d | 2016-10-17 | 2016-10-30 | PR-Z4-EW-EL-179-130 | 320.2d | 0d |  |  | OK | 1.2.9.30 | PROC | PROC |
| PR-Z4-EW-EL-179-150 |  | NMR 601 - Grounding Rod & Accessories |  | 4.8d | 2016-10-30 | 2016-11-05 | PR-Z4-EW-EL-179-140 | 320.2d | 0d |  |  | OK | 1.2.9.30 | PROC | PROC |
| PR-Z4-EW-EL-179-160 |  | NMR 602 - Grounding Rod & Accessories |  | 4.8d | 2016-11-05 | 2016-11-10 | PR-Z4-EW-EL-179-150 | 320.2d | 0d |  |  | OK | 1.2.9.30 | PROC | PROC |
| PR-Z4-EW-EL-179-170 |  | Start of Material Delivery - Grounding Rod & Accessories | milestone | 0d | 2016-12-19 | 2016-12-19 | PR-Z4-EW-EL-179-160 FS+33.6d | 320.2d | 0d |  |  | OK | 1.2.9.30 | PROC | PROC |
| PR-Z4-EW-EL-179-180 |  | Complete Material Delivery - Grounding Rod & Accessories |  | 12d | 2016-12-19 | 2017-01-02 | PR-Z4-EW-EL-179-170 | 320.2d | 0d | Ground Cable and Accessories [1 Lm] | 2,899 | OK | 1.2.9.30 | PROC | PROC |
| PR-Z4-EW-EL-179-190 |  | NMR 603 - Grounding Rod & Accessories |  | 8d | 2017-01-02 | 2017-01-11 | PR-Z4-EW-EL-179-180 | 320.2d | 238d |  |  | OK | 1.2.9.30 | PROC | PROC |
|  | 3 | **Concrete Foundations incl. accessories** |  |  | 2016-08-28 | 2017-02-01 |  |  |  |  |  |  |  |  |  |
| PR-Z4-EW-EL-180-0010 |  | RFQ - Concrete Foundations incl. accessories |  | 12d | 2016-08-28 | 2016-09-15 | PROC-GE-GE-GE-0010 FS+16d | 147.2d | 0d |  |  | OK | 1.2.9.30 | PROC | PROC |
| PR-Z4-EW-EL-180-0020 |  | Material Submittal - Concrete Foundations incl. accessories |  | 8d | 2016-09-15 | 2016-09-25 | PR-Z4-EW-EL-180-0010 | 147.2d | 0d |  |  | OK | 1.2.9.30 | PROC | PROC |
| PR-Z4-EW-EL-180-0030 |  | Material Approval - Concrete Foundations incl. accessories |  | 11.2d | 2016-09-25 | 2016-10-08 | PR-Z4-EW-EL-180-0020 | 147.2d | 0d |  |  | OK | 1.2.9.30 | PROC | PROC |
| PR-Z4-EW-EL-180-0040 |  | Technical Evaluation - Concrete Foundations incl. accessories |  | 8d | 2016-10-08 | 2016-10-17 | PR-Z4-EW-EL-180-0030 | 147.2d | 0d |  |  | OK | 1.2.9.30 | PROC | PROC |
| PR-Z4-EW-EL-180-0050 |  | PO - Concrete Foundations incl. accessories |  | 11.2d | 2016-10-17 | 2016-10-30 | PR-Z4-EW-EL-180-0040 | 147.2d | 0d |  |  | OK | 1.2.9.30 | PROC | PROC |
| PR-Z4-EW-EL-180-0060 |  | NMR 601 - Concrete Foundations incl. accessories |  | 4.8d | 2016-10-30 | 2016-11-05 | PR-Z4-EW-EL-180-0050 | 147.2d | 0d |  |  | OK | 1.2.9.30 | PROC | PROC |
| PR-Z4-EW-EL-180-0070 |  | NMR 602 - Concrete Foundations incl. accessories |  | 4.8d | 2016-11-05 | 2016-11-10 | PR-Z4-EW-EL-180-0060 | 147.2d | 0d |  |  | OK | 1.2.9.30 | PROC | PROC |
| PR-Z4-EW-EL-180-0080 |  | Start of Material Delivery - Concrete Foundations incl. accessories | milestone | 0d | 2016-12-19 | 2016-12-19 | PR-Z4-EW-EL-180-0070 FS+33.6d | 147.2d | 0d |  |  | OK | 1.2.9.30 | PROC | PROC |
| PR-Z4-EW-EL-180-0090 |  | Complete Material Delivery - Concrete Foundations incl. accessories |  | 30d | 2016-12-19 | 2017-01-23 | PR-Z4-EW-EL-180-0080 | 302.2d | 0d | Concrete Foundation [1 ea] | 3,202.14 | OK | 1.2.9.30 | PROC | PROC |
| PR-Z4-EW-EL-180-0100 |  | NMR 603 - Concrete Foundations incl. accessories |  | 8d | 2017-01-23 | 2017-02-01 | PR-Z4-EW-EL-180-0090 | 302.2d | 220d |  |  | OK | 1.2.9.30 | PROC | PROC |
|  | 3 | **COMMUNICATION WORKS (MATERIAL)** |  |  | 2016-08-23 | 2017-03-28 |  |  |  |  |  |  |  |  |  |
|  | 1 | **Communication and Security Systems** |  |  | 2016-08-23 | 2017-03-28 |  |  |  |  |  |  |  |  |  |
|  | 1 | **Coaxial Cable** |  |  | 2016-10-06 | 2017-02-12 |  |  |  |  |  |  |  |  |  |
| PR-Z4-CO-LV-181-0010 |  | RFQ - Coaxial Cables |  | 5.6d | 2016-10-06 | 2016-10-13 | PROC-GE-GE-GE-0010 FS+46.4d | 117d | 0d |  |  | OK | 1.2.10.10 | PROC | PROC |
| PR-Z4-CO-LV-181-0020 |  | Material Submittal - Coaxial Cables |  | 8d | 2016-10-13 | 2016-10-23 | PR-Z4-CO-LV-181-0010 | 117d | 0d |  |  | OK | 1.2.10.10 | PROC | PROC |
| PR-Z4-CO-LV-181-0030 |  | Material Approval - Coaxial Cables |  | 11.2d | 2016-10-23 | 2016-11-05 | PR-Z4-CO-LV-181-0020 | 117d | 0d |  |  | OK | 1.2.10.10 | PROC | PROC |
| PR-Z4-CO-LV-181-0040 |  | Technical Evaluation - Coaxial Cables |  | 8d | 2016-11-05 | 2016-11-14 | PR-Z4-CO-LV-181-0030 | 117d | 0d |  |  | OK | 1.2.10.10 | PROC | PROC |
| PR-Z4-CO-LV-181-0050 |  | PO - Coaxial Cables |  | 11.2d | 2016-11-14 | 2016-11-27 | PR-Z4-CO-LV-181-0040 | 117d | 0d |  |  | OK | 1.2.10.10 | PROC | PROC |
| PR-Z4-CO-LV-181-0060 |  | NMR 601 - Coaxial Cables |  | 4.8d | 2016-11-27 | 2016-12-03 | PR-Z4-CO-LV-181-0050 | 117d | 0d |  |  | OK | 1.2.10.10 | PROC | PROC |
| PR-Z4-CO-LV-181-0070 |  | NMR 602 - Coaxial Cables |  | 4.8d | 2016-12-03 | 2016-12-08 | PR-Z4-CO-LV-181-0060 | 117d | 0d |  |  | OK | 1.2.10.10 | PROC | PROC |
| PR-Z4-CO-LV-181-0080 |  | Start of Material Delivery - Coaxial Cables | milestone | 0d | 2017-01-21 | 2017-01-21 | PR-Z4-CO-LV-181-0070 FS+36.8d | 117d | 0d |  |  | OK | 1.2.10.10 | PROC | PROC |
| PR-Z4-CO-LV-181-0090 |  | Complete Material Delivery - Coaxial Cables |  | 12d | 2017-01-21 | 2017-02-02 | PR-Z4-CO-LV-181-0080 | 117d | 0d | Co-Axial Cables [140 Lm] | 4,657.69 | OK | 1.2.10.10 | PROC | PROC |
| PR-Z4-CO-LV-181-0100 |  | NMR 603 - Coaxial Cables |  | 8d | 2017-02-04 | 2017-02-12 | PR-Z4-CO-LV-181-0090 | 293d | 210.8d |  |  | OK | 1.2.10.10 | PROC | PROC |

Notes:
- PR-Z4-EW-EL-179-180: Expenses: (New Expense Item) 2899
- PR-Z4-EW-EL-180-0090: Expenses: (New Expense Item) 3202.14
- PR-Z4-CO-LV-181-0090: Expenses: (New Expense Item) 4657.69

| ID | WBS | Activity | Type | Duration | Start | Finish | Predecessors | Total float | Free float | Resources | Cost | Wajid | RPI_P2 - BOQ ITEMS | RPI_P2 - PROCUREMENT | RPI_P2 - PHASE |
| --- | --- | --- | --- | --- | --- | --- | --- | --- | --- | --- | --- | --- | --- | --- | --- |
|  | 2 | **FOC Splicing** |  |  | 2016-09-24 | 2017-03-16 |  |  |  |  |  |  |  |  |  |
| PR-Z4-CO-LV-182-0010 |  | RFQ - FOC Splicing |  | 12d | 2016-09-24 | 2016-10-08 | PROC-GE-GE-GE-0010 FS+35d | 265.2d | 0d |  |  | OK | 1.2.10.10 | PROC | PROC |
| PR-Z4-CO-LV-182-0020 |  | Material Submittal - FOC Splicing |  | 8d | 2016-10-08 | 2016-10-17 | PR-Z4-CO-LV-182-0010 | 265.2d | 0d |  |  | OK | 1.2.10.10 | PROC | PROC |
| PR-Z4-CO-LV-182-0030 |  | Material Approval - FOC Splicing |  | 11.2d | 2016-10-17 | 2016-10-30 | PR-Z4-CO-LV-182-0020 | 265.2d | 0d |  |  | OK | 1.2.10.10 | PROC | PROC |
| PR-Z4-CO-LV-182-0040 |  | Technical Evaluation - FOC Splicing |  | 8d | 2016-10-30 | 2016-11-08 | PR-Z4-CO-LV-182-0030 | 265.2d | 0d |  |  | OK | 1.2.10.10 | PROC | PROC |
| PR-Z4-CO-LV-182-0050 |  | PO - FOC Splicing |  | 11.2d | 2016-11-08 | 2016-11-21 | PR-Z4-CO-LV-182-0040 | 265.2d | 0d |  |  | OK | 1.2.10.10 | PROC | PROC |
| PR-Z4-CO-LV-182-0060 |  | NMR 601 - FOC Splicing |  | 4.8d | 2016-11-21 | 2016-11-27 | PR-Z4-CO-LV-182-0050 | 265.2d | 0d |  |  | OK | 1.2.10.10 | PROC | PROC |
| PR-Z4-CO-LV-182-0070 |  | NMR 602 - FOC Splicing |  | 4.8d | 2016-11-27 | 2016-12-03 | PR-Z4-CO-LV-182-0060 | 265.2d | 0d |  |  | OK | 1.2.10.10 | PROC | PROC |
| PR-Z4-CO-LV-182-0080 |  | Start of Material Delivery - FOC Splicing | milestone | 0d | 2017-02-21 | 2017-02-21 | PR-Z4-CO-LV-182-0070 FS+69.6d | 265.2d | 0d |  |  | OK | 1.2.10.10 | PROC | PROC |
| PR-Z4-CO-LV-182-0090 |  | Complete Material Delivery - FOC Splicing |  | 12d | 2017-02-21 | 2017-03-07 | PR-Z4-CO-LV-182-0080 | 265.2d | 0d | Splicing FOC [5 ea] | 40,056.11 | OK | 1.2.10.10 | PROC | PROC |
| PR-Z4-CO-LV-182-0100 |  | NMR 603 - FOC Splicing |  | 8d | 2017-03-07 | 2017-03-16 | PR-Z4-CO-LV-182-0090 | 265.2d | 183d |  |  | OK | 1.2.10.10 | PROC | PROC |
|  | 3 | **Sand for Backfilling** |  |  | 2016-08-23 | 2017-01-24 |  |  |  |  |  |  |  |  |  |
| PR-Z4-CO-LV-183-0010 |  | RFQ - Sand for Backfilling |  | 12d | 2016-08-23 | 2016-09-05 | PROC-GE-GE-GE-0010 FS+12d | 309.8d | 0d |  |  | OK | 1.2.10.10 | PROC | PROC |
| PR-Z4-CO-LV-183-0020 |  | Material Submittal - Sand for Backfilling |  | 8d | 2016-09-06 | 2016-09-20 | PR-Z4-CO-LV-183-0010 | 309.8d | 0d |  |  | OK | 1.2.10.10 | PROC | PROC |
| PR-Z4-CO-LV-183-0030 |  | Material Approval - Sand for Backfilling |  | 11.2d | 2016-09-20 | 2016-10-03 | PR-Z4-CO-LV-183-0020 | 309.8d | 0d |  |  | OK | 1.2.10.10 | PROC | PROC |
| PR-Z4-CO-LV-183-0040 |  | Technical Evaluation - Sand for Backfilling |  | 8d | 2016-10-03 | 2016-10-12 | PR-Z4-CO-LV-183-0030 | 309.8d | 0d |  |  | OK | 1.2.10.10 | PROC | PROC |
| PR-Z4-CO-LV-183-0050 |  | PO - Sand for Backfilling |  | 11.2d | 2016-10-12 | 2016-10-25 | PR-Z4-CO-LV-183-0040 | 309.8d | 0d |  |  | OK | 1.2.10.10 | PROC | PROC |
| PR-Z4-CO-LV-183-0060 |  | NMR 601 - Sand for Backfilling |  | 4.8d | 2016-10-25 | 2016-10-31 | PR-Z4-CO-LV-183-0050 | 309.8d | 0d |  |  | OK | 1.2.10.10 | PROC | PROC |
| PR-Z4-CO-LV-183-0070 |  | NMR 602 - Sand for Backfilling |  | 4.8d | 2016-10-31 | 2016-11-06 | PR-Z4-CO-LV-183-0060 | 309.8d | 0d |  |  | OK | 1.2.10.10 | PROC | PROC |
| PR-Z4-CO-LV-183-0080 |  | Start of Material Delivery - Sand for Backfilling | milestone | 0d | 2016-11-06 | 2016-11-06 | PR-Z4-CO-LV-183-0070 | 309.8d | 0d |  |  | OK | 1.2.10.10 | PROC | PROC |
| PR-Z4-CO-LV-183-0090 |  | Complete Material Delivery - Sand for Backfilling |  | 60d | 2016-11-06 | 2017-01-15 | PR-Z4-CO-LV-183-0080 | 309.8d | 0d | Sand for Backfilling [146 Cum] | 9,364.03 | OK | 1.2.10.10 | PROC | PROC |
| PR-Z4-CO-LV-183-0100 |  | NMR 603 - Sand for Backfilling |  | 8d | 2017-01-15 | 2017-01-24 | PR-Z4-CO-LV-183-0090 | 309.8d | 227.6d |  |  | OK | 1.2.10.10 | PROC | PROC |
|  | 4 | **Warning Tapes** |  |  | 2016-08-27 | 2016-12-13 |  |  |  |  |  |  |  |  |  |
| PR-Z4-CO-LV-184-0010 |  | RFQ - Warning Tapes |  | 12d | 2016-08-27 | 2016-09-10 | PROC-GE-GE-GE-0010 FS+15.2d | 301.8d | 0d |  |  | OK | 1.2.10.10 | PROC | PROC |
| PR-Z4-CO-LV-184-0020 |  | Material Submittal - Warning Tapes |  | 8d | 2016-09-10 | 2016-09-24 | PR-Z4-CO-LV-184-0010 | 345.8d | 0d |  |  | OK | 1.2.10.10 | PROC | PROC |
| PR-Z4-CO-LV-184-0030 |  | Material Approval - Warning Tapes |  | 11.2d | 2016-09-24 | 2016-10-06 | PR-Z4-CO-LV-184-0020 | 345.8d | 0d |  |  | OK | 1.2.10.10 | PROC | PROC |
| PR-Z4-CO-LV-184-0040 |  | Technical Evaluation - Warning Tapes |  | 8d | 2016-10-06 | 2016-10-16 | PR-Z4-CO-LV-184-0030 | 345.8d | 0d |  |  | OK | 1.2.10.10 | PROC | PROC |
| PR-Z4-CO-LV-184-0050 |  | PO - Warning Tapes |  | 11.2d | 2016-10-16 | 2016-10-29 | PR-Z4-CO-LV-184-0040 | 345.8d | 0d |  |  | OK | 1.2.10.10 | PROC | PROC |
| PR-Z4-CO-LV-184-0060 |  | NMR 601 - Warning Tapes |  | 4.8d | 2016-10-29 | 2016-11-03 | PR-Z4-CO-LV-184-0050 | 345.8d | 0d |  |  | OK | 1.2.10.10 | PROC | PROC |
| PR-Z4-CO-LV-184-0070 |  | NMR 602 - Warning Tapes |  | 4.8d | 2016-11-03 | 2016-11-09 | PR-Z4-CO-LV-184-0060 | 345.8d | 0d |  |  | OK | 1.2.10.10 | PROC | PROC |
| PR-Z4-CO-LV-184-0080 |  | Start of Material Delivery - Warning Tapes | milestone | 0d | 2016-11-15 | 2016-11-15 | PR-Z4-CO-LV-184-0070 FS+4.8d | 345.8d | 0d |  |  | OK | 1.2.10.10 | PROC | PROC |
| PR-Z4-CO-LV-184-0090 |  | Complete Material Delivery - Warning Tapes |  | 16d | 2016-11-15 | 2016-12-04 | PR-Z4-CO-LV-184-0080 | 345.8d | 0d | Warning Tapes [1759 Lm] | 5,852.05 | OK | 1.2.10.10 | PROC | PROC |
| PR-Z4-CO-LV-184-0100 |  | NMR 603 - Warning Tapes |  | 8d | 2016-12-04 | 2016-12-13 | PR-Z4-CO-LV-184-0090 | 345.8d | 263.6d |  |  | OK | 1.2.10.10 | PROC | PROC |

Notes:
- PR-Z4-CO-LV-182-0090: Expenses: (New Expense Item) 40056.1
- PR-Z4-CO-LV-183-0090: Expenses: (New Expense Item) 9364.03
- PR-Z4-CO-LV-184-0090: Expenses: (New Expense Item) 5852.05

| ID | WBS | Activity | Type | Duration | Start | Finish | Predecessors | Total float | Free float | Resources | Cost | Wajid | RPI_P2 - BOQ ITEMS | RPI_P2 - PROCUREMENT | RPI_P2 - PHASE |
| --- | --- | --- | --- | --- | --- | --- | --- | --- | --- | --- | --- | --- | --- | --- | --- |
|  | 5 | **Red Tiles** |  |  | 2016-08-27 | 2017-02-02 |  |  |  |  |  |  |  |  |  |
| PR-Z4-CO-LV-184-100 |  | RFQ - Red Tiles |  | 12d | 2016-08-27 | 2016-09-10 | PR-Z4-CO-LV-184-0010 SS | 301.8d | 0d |  |  | OK | 1.2.10.10 | PROC | PROC |
| PR-Z4-CO-LV-184-110 |  | Material Submittal - Red Tiles |  | 8d | 2016-09-10 | 2016-09-24 | PR-Z4-CO-LV-184-100 | 301.8d | 0d |  |  | OK | 1.2.10.10 | PROC | PROC |
| PR-Z4-CO-LV-184-120 |  | Material Approval - Red Tiles |  | 11.2d | 2016-09-24 | 2016-10-06 | PR-Z4-CO-LV-184-110 | 301.8d | 0d |  |  | OK | 1.2.10.10 | PROC | PROC |
| PR-Z4-CO-LV-184-130 |  | Technical Evaluation - Red Tiles |  | 8d | 2016-10-06 | 2016-10-16 | PR-Z4-CO-LV-184-120 | 301.8d | 0d |  |  | OK | 1.2.10.10 | PROC | PROC |
| PR-Z4-CO-LV-184-140 |  | PO - Red Tiles |  | 11.2d | 2016-10-16 | 2016-10-29 | PR-Z4-CO-LV-184-130 | 301.8d | 0d |  |  | OK | 1.2.10.10 | PROC | PROC |
| PR-Z4-CO-LV-184-150 |  | NMR 601 - Red Tiles |  | 4.8d | 2016-10-29 | 2016-11-03 | PR-Z4-CO-LV-184-140 | 301.8d | 0d |  |  | OK | 1.2.10.10 | PROC | PROC |
| PR-Z4-CO-LV-184-160 |  | NMR 602 - Red Tiles |  | 4.8d | 2016-11-03 | 2016-11-09 | PR-Z4-CO-LV-184-150 | 301.8d | 0d |  |  | OK | 1.2.10.10 | PROC | PROC |
| PR-Z4-CO-LV-184-170 |  | Start of Material Delivery - Red Tiles | milestone | 0d | 2016-11-15 | 2016-11-15 | PR-Z4-CO-LV-184-160 FS+4.8d | 301.8d | 0d |  |  | OK | 1.2.10.10 | PROC | PROC |
| PR-Z4-CO-LV-184-180 |  | Complete Material Delivery - Red Tiles |  | 60d | 2016-11-15 | 2017-01-24 | PR-Z4-CO-LV-184-170 | 301.8d | 0d | Red Tiles [8795 ea] | 29,260.26 | OK | 1.2.10.10 | PROC | PROC |
| PR-Z4-CO-LV-184-190 |  | NMR 603 - Red Tiles |  | 8d | 2017-01-24 | 2017-02-02 | PR-Z4-CO-LV-184-180 | 301.8d | 219.6d |  |  | OK | 1.2.10.10 | PROC | PROC |
|  | 6 | **FOC - Fiber Optic Cables** |  |  | 2016-09-01 | 2017-02-27 |  |  |  |  |  |  |  |  |  |
| PR-Z4-CO-LV-185-0010 |  | RFQ - Fiber Optic Cables (FOC) |  | 12d | 2016-09-01 | 2016-09-20 | PROC-GE-GE-GE-0010 FS+20d | 104.2d | 0d |  |  | OK | 1.2.10.10 | PROC | PROC |
| PR-Z4-CO-LV-185-0020 |  | Material Submittal - Fiber Optic Cables (FOC) |  | 8d | 2016-09-20 | 2016-09-29 | PR-Z4-CO-LV-185-0010 | 104.2d | 0d |  |  | OK | 1.2.10.10 | PROC | PROC |
| PR-Z4-CO-LV-185-0030 |  | Material Approval - Fiber Optic Cables (FOC) |  | 11.2d | 2016-09-29 | 2016-10-12 | PR-Z4-CO-LV-185-0020 | 104.2d | 0d |  |  | OK | 1.2.10.10 | PROC | PROC |
| PR-Z4-CO-LV-185-0040 |  | Technical Evaluation - Fiber Optic Cables (FOC) |  | 8d | 2016-10-12 | 2016-10-22 | PR-Z4-CO-LV-185-0030 | 104.2d | 0d |  |  | OK | 1.2.10.10 | PROC | PROC |
| PR-Z4-CO-LV-185-0050 |  | PO - Fiber Optic Cables (FOC) |  | 11.2d | 2016-10-22 | 2016-11-03 | PR-Z4-CO-LV-185-0040 | 104.2d | 0d |  |  | OK | 1.2.10.10 | PROC | PROC |
| PR-Z4-CO-LV-185-0060 |  | NMR 601 - Fiber Optic Cables (FOC) |  | 4.8d | 2016-11-03 | 2016-11-09 | PR-Z4-CO-LV-185-0050 | 104.2d | 0d |  |  | OK | 1.2.10.10 | PROC | PROC |
| PR-Z4-CO-LV-185-0070 |  | NMR 602 - Fiber Optic Cables (FOC) |  | 4.8d | 2016-11-09 | 2016-11-15 | PR-Z4-CO-LV-185-0060 | 104.2d | 0d |  |  | OK | 1.2.10.10 | PROC | PROC |
| PR-Z4-CO-LV-185-0080 |  | Start of Material Delivery - Fiber Optic Cables (FOC) | milestone | 0d | 2017-02-04 | 2017-02-04 | PR-Z4-CO-LV-185-0070 FS+69.6d | 104.2d | 0d |  |  | OK | 1.2.10.10 | PROC | PROC |
| PR-Z4-CO-LV-185-0090 |  | Complete Material Delivery - Fiber Optic Cables (FOC) |  | 12d | 2017-02-04 | 2017-02-18 | PR-Z4-CO-LV-185-0080 | 104.2d | 0d | FOC - Fiber Optic Cables [1297.05 Lm] | 103,563.01 | OK | 1.2.10.10 | PROC | PROC |
| PR-Z4-CO-LV-185-0100 |  | NMR 603 - Fiber Optic Cables (FOC) |  | 8d | 2017-02-18 | 2017-02-27 | PR-Z4-CO-LV-185-0090 | 280.2d | 198d |  |  | OK | 1.2.10.10 | PROC | PROC |
|  | 7 | **Copper Cables & Copper Splices** |  |  | 2016-09-01 | 2017-02-27 |  |  |  |  |  |  |  |  |  |
| PR-Z4-CO-LV-186-0010 |  | RFQ - Copper Cables & Copper Splices |  | 12d | 2016-09-01 | 2016-09-20 | PROC-GE-GE-GE-0010 FS+20d | 104.2d | 0d |  |  | OK | 1.2.10.10 | PROC | PROC |
| PR-Z4-CO-LV-186-0020 |  | Material Submittal - Copper Cables & Copper Splices |  | 8d | 2016-09-20 | 2016-09-29 | PR-Z4-CO-LV-186-0010 | 104.2d | 0d |  |  | OK | 1.2.10.10 | PROC | PROC |
| PR-Z4-CO-LV-186-0030 |  | Material Approval - Copper Cables & Copper Splices |  | 11.2d | 2016-09-29 | 2016-10-12 | PR-Z4-CO-LV-186-0020 | 104.2d | 0d |  |  | OK | 1.2.10.10 | PROC | PROC |
| PR-Z4-CO-LV-186-0040 |  | Technical Evaluation - Copper Cables & Copper Splices |  | 8d | 2016-10-12 | 2016-10-22 | PR-Z4-CO-LV-186-0030 | 104.2d | 0d |  |  | OK | 1.2.10.10 | PROC | PROC |
| PR-Z4-CO-LV-186-0050 |  | PO - Copper Cables & Copper Splices |  | 11.2d | 2016-10-22 | 2016-11-03 | PR-Z4-CO-LV-186-0040 | 104.2d | 0d |  |  | OK | 1.2.10.10 | PROC | PROC |
| PR-Z4-CO-LV-186-0060 |  | NMR 601 - Copper Cables & Copper Splices |  | 4.8d | 2016-11-03 | 2016-11-09 | PR-Z4-CO-LV-186-0050 | 104.2d | 0d |  |  | OK | 1.2.10.10 | PROC | PROC |
| PR-Z4-CO-LV-186-0070 |  | NMR 602 - Copper Cables & Copper Splices |  | 4.8d | 2016-11-09 | 2016-11-15 | PR-Z4-CO-LV-186-0060 | 104.2d | 0d |  |  | OK | 1.2.10.10 | PROC | PROC |
| PR-Z4-CO-LV-186-0080 |  | Start of Material Delivery - Copper Cables & Copper Splices | milestone | 0d | 2017-02-04 | 2017-02-04 | PR-Z4-CO-LV-186-0070 FS+69.6d | 104.2d | 0d |  |  | OK | 1.2.10.10 | PROC | PROC |
| PR-Z4-CO-LV-186-0090 |  | Complete Material Delivery - Copper Cables & Copper Splices |  | 12d | 2017-02-04 | 2017-02-18 | PR-Z4-CO-LV-186-0080 | 104.2d | 0d | FOC - Copper Cables [525 Lm] | 52,033.02 | OK | 1.2.10.10 | PROC | PROC |
| PR-Z4-CO-LV-186-0100 |  | NMR 603 - Copper Cables & Copper Splices |  | 8d | 2017-02-18 | 2017-02-27 | PR-Z4-CO-LV-186-0090 | 280.2d | 198d |  |  | OK | 1.2.10.10 | PROC | PROC |

Notes:
- PR-Z4-CO-LV-184-180: Expenses: (New Expense Item) 29260.3
- PR-Z4-CO-LV-185-0090: Expenses: (New Expense Item) 103563
- PR-Z4-CO-LV-186-0090: Expenses: (New Expense Item) 52033

| ID | WBS | Activity | Type | Duration | Start | Finish | Predecessors | Total float | Free float | Resources | Cost | Wajid | RPI_P2 - BOQ ITEMS | RPI_P2 - PROCUREMENT | RPI_P2 - PHASE |
| --- | --- | --- | --- | --- | --- | --- | --- | --- | --- | --- | --- | --- | --- | --- | --- |
|  | 8 | **Code Blue Pedestals** |  |  | 2016-10-08 | 2017-03-28 |  |  |  |  |  |  |  |  |  |
| PR-Z4-CO-LV-187-0010 |  | RFQ - Code Blue Pedestals |  | 5.6d | 2016-10-08 | 2016-10-13 | PROC-GE-GE-GE-0010 FS+47.2d | 255d | 0d |  |  | OK | 1.2.10.10 | PROC | PROC |
| PR-Z4-CO-LV-187-0020 |  | Material Submittal - Code Blue Pedestals |  | 8d | 2016-10-15 | 2016-10-23 | PR-Z4-CO-LV-187-0010 | 255d | 0d |  |  | OK | 1.2.10.10 | PROC | PROC |
| PR-Z4-CO-LV-187-0030 |  | Material Approval - Code Blue Pedestals |  | 11.2d | 2016-10-24 | 2016-11-06 | PR-Z4-CO-LV-187-0020 | 255d | 0d |  |  | OK | 1.2.10.10 | PROC | PROC |
| PR-Z4-CO-LV-187-0040 |  | Technical Evaluation - Code Blue Pedestals |  | 0d | 2016-11-06 | 2016-11-06 | PR-Z4-CO-LV-187-0030 | 255d | 0d |  |  | OK | 1.2.10.10 | PROC | PROC |
| PR-Z4-CO-LV-187-0050 |  | PO - Code Blue Pedestals |  | 11.2d | 2016-11-06 | 2016-11-19 | PR-Z4-CO-LV-187-0040 | 255d | 0d |  |  | OK | 1.2.10.10 | PROC | PROC |
| PR-Z4-CO-LV-187-0060 |  | NMR 601 - Code Blue Pedestals |  | 12d | 2016-11-19 | 2016-12-03 | PR-Z4-CO-LV-187-0050 | 255d | 0d |  |  | OK | 1.2.10.10 | PROC | PROC |
| PR-Z4-CO-LV-187-0070 |  | NMR 602 - Code Blue Pedestals |  | 12d | 2016-12-03 | 2016-12-17 | PR-Z4-CO-LV-187-0060 | 255d | 0d |  |  | OK | 1.2.10.10 | PROC | PROC |
| PR-Z4-CO-LV-187-0080 |  | Start of Material Delivery - Code Blue Pedestals | milestone | 0d | 2017-02-27 | 2017-02-27 | PR-Z4-CO-LV-187-0070 FS+61.6d | 255d | 0d |  |  | OK | 1.2.10.10 | PROC | PROC |
| PR-Z4-CO-LV-187-0090 |  | Complete Material Delivery - Code Blue Pedestals |  | 18d | 2017-02-27 | 2017-03-19 | PR-Z4-CO-LV-187-0080 | 255d | 0d | Code Blue Pedestal [3 ea] | 179,653.66 | OK | 1.2.10.10 | PROC | PROC |
| PR-Z4-CO-LV-187-0100 |  | NMR 603 - Code Blue Pedestals |  | 8d | 2017-03-20 | 2017-03-28 | PR-Z4-CO-LV-187-0090 | 255d | 172.8d |  |  | OK | 1.2.10.10 | PROC | PROC |
|  | 9 | **Code Blue LV Cables** |  |  | 2016-10-08 | 2017-03-05 |  |  |  |  |  |  |  |  |  |
| PR-Z4-CO-LV-188-0010 |  | RFQ - Code Blue LV Cables |  | 5.6d | 2016-10-08 | 2016-10-13 | PROC-GE-GE-GE-0010 FS+47.2d | 275.2d | 0d |  |  | OK | 1.2.10.10 | PROC | PROC |
| PR-Z4-CO-LV-188-0020 |  | Material Submittal - Code Blue LV Cables |  | 8d | 2016-10-15 | 2016-10-23 | PR-Z4-CO-LV-188-0010 | 275.2d | 0d |  |  | OK | 1.2.10.10 | PROC | PROC |
| PR-Z4-CO-LV-188-0030 |  | Material Approval - Code Blue LV Cables |  | 11.2d | 2016-10-24 | 2016-11-06 | PR-Z4-CO-LV-188-0020 | 275.2d | 0d |  |  | OK | 1.2.10.10 | PROC | PROC |
| PR-Z4-CO-LV-188-0040 |  | Technical Evaluation - Code Blue LV Cables |  | 8d | 2016-11-06 | 2016-11-15 | PR-Z4-CO-LV-188-0030 | 275.2d | 0d |  |  | OK | 1.2.10.10 | PROC | PROC |
| PR-Z4-CO-LV-188-0050 |  | PO - Code Blue LV Cables |  | 11.2d | 2016-11-15 | 2016-11-28 | PR-Z4-CO-LV-188-0040 | 275.2d | 0d |  |  | OK | 1.2.10.10 | PROC | PROC |
| PR-Z4-CO-LV-188-0060 |  | NMR 601 - Code Blue LV Cables |  | 5d | 2016-11-28 | 2016-12-04 | PR-Z4-CO-LV-188-0050 | 275.2d | 0d |  |  | OK | 1.2.10.10 | PROC | PROC |
| PR-Z4-CO-LV-188-0070 |  | NMR 602 - Code Blue LV Cables |  | 4.8d | 2016-12-04 | 2016-12-10 | PR-Z4-CO-LV-188-0060 | 275.2d | 0d |  |  | OK | 1.2.10.10 | PROC | PROC |
| PR-Z4-CO-LV-188-0080 |  | Start of Material Delivery - Code Blue LV Cables | milestone | 0d | 2017-02-09 | 2017-02-09 | PR-Z4-CO-LV-188-0070 FS+53.6d | 275.2d | 0d |  |  | OK | 1.2.10.10 | PROC | PROC |
| PR-Z4-CO-LV-188-0090 |  | Complete Material Delivery - Code Blue LV Cables |  | 12d | 2017-02-09 | 2017-02-23 | PR-Z4-CO-LV-188-0080 | 275.2d | 0d | Code Blue LV Cables [978 Lm] | 17,674.25 | OK | 1.2.10.10 | PROC | PROC |
| PR-Z4-CO-LV-188-0100 |  | NMR 603 - Code Blue LV Cables |  | 8d | 2017-02-23 | 2017-03-05 | PR-Z4-CO-LV-188-0090 | 275.2d | 193d |  |  | OK | 1.2.10.10 | PROC | PROC |
|  | 10 | **Concrete Foundation for Code Blue Pedestals** |  |  | 2016-10-08 | 2017-03-05 |  |  |  |  |  |  |  |  |  |
| PR-Z4-CO-LV-189-0010 |  | RFQ - Concrete Foundation for Code Blue Pedestals |  | 5.6d | 2016-10-08 | 2016-10-13 | PROC-GE-GE-GE-0010 FS+47.2d | 275.4d | 0d |  |  | OK | 1.2.10.10 | PROC | PROC |
| PR-Z4-CO-LV-189-0020 |  | Material Submittal - Concrete Foundation for Code Blue Pedestals |  | 8d | 2016-10-15 | 2016-10-23 | PR-Z4-CO-LV-189-0010 | 275.4d | 0d |  |  | OK | 1.2.10.10 | PROC | PROC |
| PR-Z4-CO-LV-189-0030 |  | Material Approval - Concrete Foundation for Code Blue Pedestals |  | 11.2d | 2016-10-24 | 2016-11-06 | PR-Z4-CO-LV-189-0020 | 275.4d | 0d |  |  | OK | 1.2.10.10 | PROC | PROC |
| PR-Z4-CO-LV-189-0040 |  | Technical Evaluation - Concrete Foundation for Code Blue Pedestals |  | 8d | 2016-11-06 | 2016-11-15 | PR-Z4-CO-LV-189-0030 | 275.4d | 0d |  |  | OK | 1.2.10.10 | PROC | PROC |
| PR-Z4-CO-LV-189-0050 |  | PO - Concrete Foundation for Code Blue Pedestals |  | 11.2d | 2016-11-15 | 2016-11-28 | PR-Z4-CO-LV-189-0040 | 275.4d | 0d |  |  | OK | 1.2.10.10 | PROC | PROC |
| PR-Z4-CO-LV-189-0060 |  | NMR 601 - Concrete Foundation for Code Blue Pedestals |  | 4.8d | 2016-11-28 | 2016-12-04 | PR-Z4-CO-LV-189-0050 | 275.4d | 0d |  |  | OK | 1.2.10.10 | PROC | PROC |
| PR-Z4-CO-LV-189-0070 |  | NMR 602 - Concrete Foundation for Code Blue Pedestals |  | 4.8d | 2016-12-04 | 2016-12-08 | PR-Z4-CO-LV-189-0060 | 275.4d | 0d |  |  | OK | 1.2.10.10 | PROC | PROC |
| PR-Z4-CO-LV-189-0080 |  | Start of Material Delivery - Concrete Foundation for Code Blue Pedestals | milestone | 0d | 2017-02-09 | 2017-02-09 | PR-Z4-CO-LV-189-0070 FS+53.6d | 275.4d | 0d |  |  | OK | 1.2.10.10 | PROC | PROC |
| PR-Z4-CO-LV-189-0090 |  | Complete Material Delivery - Concrete Foundation for Code Blue Pedestals |  | 12d | 2017-02-09 | 2017-02-23 | PR-Z4-CO-LV-189-0080 | 275.4d | 0d | Concrete Foundation [3 ea] | 3,393.46 | OK | 1.2.10.10 | PROC | PROC |
| PR-Z4-CO-LV-189-0100 |  | NMR 603 - Concrete Foundation for Code Blue Pedestals |  | 8d | 2017-02-23 | 2017-03-05 | PR-Z4-CO-LV-189-0090 | 275.4d | 193.2d |  |  | OK | 1.2.10.10 | PROC | PROC |

Notes:
- PR-Z4-CO-LV-187-0090: Expenses: (New Expense Item) 179654
- PR-Z4-CO-LV-188-0090: Expenses: (New Expense Item) 17674.2
- PR-Z4-CO-LV-189-0090: Expenses: (New Expense Item) 3393.46

| ID | WBS | Activity | Type | Duration | Start | Finish | Predecessors | Total float | Free float | Resources | Cost | Wajid | RPI_P2 - BOQ ITEMS | RPI_P2 - PROCUREMENT | RPI_P2 - PHASE |
| --- | --- | --- | --- | --- | --- | --- | --- | --- | --- | --- | --- | --- | --- | --- | --- |
|  | 2 | **Miscellaneous Communication Items** |  |  | 2016-09-01 | 2017-01-11 |  |  |  |  |  |  |  |  |  |
|  | 1 | **PVC Sub-ducts & Plugging for Communication** |  |  | 2016-09-01 | 2017-01-11 |  |  |  |  |  |  |  |  |  |
| PR-Z4-CO-LV-190-0010 |  | RFQ - PVC Sub-ducts & Plugging for Communication |  | 12d | 2016-09-01 | 2016-09-20 | PROC-GE-GE-GE-0010 FS+20d | 4.2d | 0d |  |  | OK | 1.2.10.20 | PROC | PROC |
| PR-Z4-CO-LV-190-0020 |  | Material Submittal - PVC Sub-ducts & Plugging for Communication |  | 8d | 2016-09-20 | 2016-09-29 | PR-Z4-CO-LV-190-0010 | 4.2d | 0d |  |  | OK | 1.2.10.20 | PROC | PROC |
| PR-Z4-CO-LV-190-0030 |  | Material Approval - PVC Sub-ducts & Plugging for Communication |  | 11.2d | 2016-09-29 | 2016-10-12 | PR-Z4-CO-LV-190-0020 | 4.2d | 0d |  |  | OK | 1.2.10.20 | PROC | PROC |
| PR-Z4-CO-LV-190-0040 |  | Technical Evaluation - PVC Sub-ducts & Plugging for Communication |  | 8d | 2016-10-12 | 2016-10-22 | PR-Z4-CO-LV-190-0030 | 4.2d | 0d |  |  | OK | 1.2.10.20 | PROC | PROC |
| PR-Z4-CO-LV-190-0050 |  | PO - PVC Sub-ducts & Plugging for Communication |  | 11.2d | 2016-10-22 | 2016-11-03 | PR-Z4-CO-LV-190-0040 | 4.2d | 0d |  |  | OK | 1.2.10.20 | PROC | PROC |
| PR-Z4-CO-LV-190-0060 |  | NMR 601 - PVC Sub-ducts & Plugging for Communication |  | 4.8d | 2016-11-03 | 2016-11-09 | PR-Z4-CO-LV-190-0050 | 4.2d | 0d |  |  | OK | 1.2.10.20 | PROC | PROC |
| PR-Z4-CO-LV-190-0070 |  | NMR 602 - PVC Sub-ducts & Plugging for Communication |  | 4.8d | 2016-11-09 | 2016-11-15 | PR-Z4-CO-LV-190-0060 | 4.2d | 0d |  |  | OK | 1.2.10.20 | PROC | PROC |
| PR-Z4-CO-LV-190-0080 |  | Start of Material Delivery - PVC Sub-ducts & Plugging for Communication | milestone | 0d | 2016-12-19 | 2016-12-19 | PR-Z4-CO-LV-190-0070 FS+29.6d | 4.2d | 0d |  |  | OK | 1.2.10.20 | PROC | PROC |
| PR-Z4-CO-LV-190-0090 |  | Complete Material Delivery - PVC Sub-ducts & Plugging for Communication |  | 12d | 2016-12-19 | 2017-01-02 | PR-Z4-CO-LV-190-0080 | 4.2d | 0d | Sub-ducts Plugging [1 ea]; PVC Sub-ducts [1518 Lm] | 12,907.96 | OK | 1.2.10.20 | PROC | PROC |
| PR-Z4-CO-LV-190-0100 |  | NMR 603 - PVC Sub-ducts & Plugging for Communication |  | 8d | 2017-01-02 | 2017-01-11 | PR-Z4-CO-LV-190-0090 | 320.2d | 238d |  |  | OK | 1.2.10.20 | PROC | PROC |
|  | 4 | **UTILITIES & SERVICE WORKS - (MATERIAL)** |  |  | 2016-08-25 | 2017-04-08 |  |  |  |  |  |  |  |  |  |
|  | 1 | **Potable and fire water system and related material** |  |  | 2016-08-25 | 2017-02-13 |  |  |  |  |  |  |  |  |  |
|  | 3 | **RTR Pipes & Fittings** |  |  | 2016-08-25 | 2017-01-01 |  |  |  |  |  |  |  |  |  |
| PR-Z4-UT-PW-191-0010 |  | RFQ - RTR Pipes & Fittings |  | 12d | 2016-08-25 | 2016-09-08 | PROC-GE-GE-GE-0010 FS+14.4d | 114d | 0d |  |  | OK | 1.2.11.10 | PROC | PROC |
| PR-Z4-UT-PW-191-0020 |  | Material Submittal - RTR Pipes & Fittings |  | 8d | 2016-09-08 | 2016-09-22 | PR-Z4-UT-PW-191-0010 | 114d | 0d |  |  | OK | 1.2.11.10 | PROC | PROC |
| PR-Z4-UT-PW-191-0030 |  | Material Approval - RTR Pipes & Fittings |  | 11.2d | 2016-09-22 | 2016-10-05 | PR-Z4-UT-PW-191-0020 | 114d | 0d |  |  | OK | 1.2.11.10 | PROC | PROC |
| PR-Z4-UT-PW-191-0040 |  | Technical Evaluation - RTR Pipes & Fittings |  | 8d | 2016-10-05 | 2016-10-15 | PR-Z4-UT-PW-191-0030 | 114d | 0d |  |  | OK | 1.2.11.10 | PROC | PROC |
| PR-Z4-UT-PW-191-0050 |  | PO - RTR Pipes & Fittings |  | 11.2d | 2016-10-15 | 2016-10-27 | PR-Z4-UT-PW-191-0040 | 114d | 0d |  |  | OK | 1.2.11.10 | PROC | PROC |
| PR-Z4-UT-PW-191-0060 |  | NMR 601 - RTR Pipes & Fittings |  | 12d | 2016-10-29 | 2016-11-10 | PR-Z4-UT-PW-191-0050 | 114d | 0d |  |  | OK | 1.2.11.10 | PROC | PROC |
| PR-Z4-UT-PW-191-0070 |  | NMR 602 - RTR Pipes & Fittings |  | 12d | 2016-11-12 | 2016-11-24 | PR-Z4-UT-PW-191-0060 | 114d | 0d |  |  | OK | 1.2.11.10 | PROC | PROC |
| PR-Z4-UT-PW-191-0080 |  | Start of Material Delivery - RTR Pipes & Fittings | milestone | 0d | 2016-12-10 | 2016-12-10 | PR-Z4-UT-PW-191-0070 FS+12d | 114d | 0d |  |  | OK | 1.2.11.10 | PROC | PROC |
| PR-Z4-UT-PW-191-0090 |  | Complete Material Delivery - RTR Pipes & Fittings |  | 12d | 2016-12-10 | 2016-12-22 | PR-Z4-UT-PW-191-0080 | 329d | 0d | RTR Pipes & Fittings [1324 Lm] | 317,237.64 | OK | 1.2.11.10 | PROC | PROC |
| PR-Z4-UT-PW-191-0100 |  | NMR 603 - RTR Pipes & Fittings |  | 8d | 2016-12-24 | 2017-01-01 | PR-Z4-UT-PW-191-0090 | 329d | 246.8d |  |  | OK | 1.2.11.10 | PROC | PROC |

Notes:
- PR-Z4-CO-LV-190-0090: Expenses: (New Expense Item) 12908
- PR-Z4-UT-PW-191-0090: Expenses: (New Expense Item) 317238

| ID | WBS | Activity | Type | Duration | Start | Finish | Predecessors | Total float | Free float | Resources | Cost | Wajid | RPI_P2 - BOQ ITEMS | RPI_P2 - PROCUREMENT | RPI_P2 - PHASE |
| --- | --- | --- | --- | --- | --- | --- | --- | --- | --- | --- | --- | --- | --- | --- | --- |
|  | 4 | **Concrete for Thrust Blocks** |  |  | 2016-08-30 | 2017-02-06 |  |  |  |  |  |  |  |  |  |
| PR-Z4-UT-PW-192-0010 |  | RFQ - Concrete for Thrust Blocks |  | 5.6d | 2016-08-30 | 2016-09-05 | PROC-GE-GE-GE-0010 FS+18d | 298.2d | 0d |  |  | OK | 1.2.11.10 | PROC | PROC |
| PR-Z4-UT-PW-192-0020 |  | Material Submittal - Concrete for Thrust Blocks |  | 8d | 2016-09-05 | 2016-09-19 | PR-Z4-UT-PW-192-0010 | 298.2d | 0d |  |  | OK | 1.2.11.10 | PROC | PROC |
| PR-Z4-UT-PW-192-0030 |  | Material Approval - Concrete for Thrust Blocks |  | 11.2d | 2016-09-19 | 2016-10-02 | PR-Z4-UT-PW-192-0020 | 298.2d | 0d |  |  | OK | 1.2.11.10 | PROC | PROC |
| PR-Z4-UT-PW-192-0040 |  | Technical Evaluation - Concrete for Thrust Blocks |  | 8d | 2016-10-03 | 2016-10-11 | PR-Z4-UT-PW-192-0030 | 298.2d | 0d |  |  | OK | 1.2.11.10 | PROC | PROC |
| PR-Z4-UT-PW-192-0050 |  | PO - Concrete for Thrust Blocks |  | 11.2d | 2016-10-12 | 2016-10-25 | PR-Z4-UT-PW-192-0040 | 298.2d | 0d |  |  | OK | 1.2.11.10 | PROC | PROC |
| PR-Z4-UT-PW-192-0060 |  | NMR 601 - Concrete for Thrust Blocks |  | 4.8d | 2016-10-25 | 2016-10-30 | PR-Z4-UT-PW-192-0050 | 298.2d | 0d |  |  | OK | 1.2.11.10 | PROC | PROC |
| PR-Z4-UT-PW-192-0070 |  | NMR 602 - Concrete for Thrust Blocks |  | 4.8d | 2016-10-31 | 2016-11-05 | PR-Z4-UT-PW-192-0060 | 298.2d | 0d |  |  | OK | 1.2.11.10 | PROC | PROC |
| PR-Z4-UT-PW-192-0080 |  | Start of Material Delivery - Concrete for Thrust Blocks | milestone | 0d | 2016-11-05 | 2016-11-05 | PR-Z4-UT-PW-192-0070 | 298.2d | 0d |  |  | OK | 1.2.11.10 | PROC | PROC |
| PR-Z4-UT-PW-192-0090 |  | Complete Material Delivery - Concrete for Thrust Blocks |  | 72d | 2016-11-05 | 2017-01-28 | PR-Z4-UT-PW-192-0080 | 298.2d | 0d | Ready Mix Concrete [1 m³] | 91.08 | OK | 1.2.11.10 | PROC | PROC |
| PR-Z4-UT-PW-192-0100 |  | NMR 603 - Concrete for Thrust Blocks |  | 8d | 2017-01-28 | 2017-02-06 | PR-Z4-UT-PW-192-0090 | 298.2d | 216d |  |  | OK | 1.2.11.10 | PROC | PROC |
|  | 5 | **Fire Hydrants including Break check valve** |  |  | 2016-09-18 | 2017-01-05 |  |  |  |  |  |  |  |  |  |
| PR-Z4-UT-PW-193-0010 |  | RFQ - Fire Hydrants including Break Check Valve |  | 12d | 2016-09-18 | 2016-10-02 | PROC-GE-GE-GE-0010 FS+30d | 135.6d | 0d |  |  | OK | 1.2.11.10 | PROC | PROC |
| PR-Z4-UT-PW-193-0020 |  | Material Submittal - Fire Hydrants including Break Check Valve |  | 8d | 2016-10-02 | 2016-10-11 | PR-Z4-UT-PW-193-0010 | 165.6d | 0d |  |  | OK | 1.2.11.10 | PROC | PROC |
| PR-Z4-UT-PW-193-0030 |  | Material Approval - Fire Hydrants including Break Check Valve |  | 11.2d | 2016-10-11 | 2016-10-24 | PR-Z4-UT-PW-193-0020 | 165.6d | 0d |  |  | OK | 1.2.11.10 | PROC | PROC |
| PR-Z4-UT-PW-193-0040 |  | Technical Evaluation - Fire Hydrants including Break Check Valve |  | 8d | 2016-10-24 | 2016-11-02 | PR-Z4-UT-PW-193-0030 | 165.6d | 0d |  |  | OK | 1.2.11.10 | PROC | PROC |
| PR-Z4-UT-PW-193-0050 |  | PO - Fire Hydrants including Break Check Valve |  | 11.2d | 2016-11-02 | 2016-11-15 | PR-Z4-UT-PW-193-0040 | 165.6d | 0d |  |  | OK | 1.2.11.10 | PROC | PROC |
| PR-Z4-UT-PW-193-0060 |  | NMR 601 - Fire Hydrants including Break Check Valve |  | 12d | 2016-11-15 | 2016-11-29 | PR-Z4-UT-PW-193-0050 | 165.6d | 0d |  |  | OK | 1.2.11.10 | PROC | PROC |
| PR-Z4-UT-PW-193-0070 |  | NMR 602 - Fire Hydrants including Break Check Valve |  | 12d | 2016-11-29 | 2016-12-13 | PR-Z4-UT-PW-193-0060 | 165.6d | 0d |  |  | OK | 1.2.11.10 | PROC | PROC |
| PR-Z4-UT-PW-193-0080 |  | Start of Material Delivery - Fire Hydrants including Break Check Valve | milestone | 0d | 2016-12-13 | 2016-12-13 | PR-Z4-UT-PW-193-0070 | 165.6d | 0d |  |  | OK | 1.2.11.10 | PROC | PROC |
| PR-Z4-UT-PW-193-0090 |  | Complete Material Delivery - Fire Hydrants including Break Check Valve |  | 12d | 2016-12-13 | 2016-12-27 | PR-Z4-UT-PW-193-0080 | 325.4d | 0d | Fire Hydrant including Break Check Valves [2 ea] | 29,323.07 | OK | 1.2.11.10 | PROC | PROC |
| PR-Z4-UT-PW-193-0100 |  | NMR 603 - Fire Hydrants including Break Check Valve |  | 8d | 2016-12-27 | 2017-01-05 | PR-Z4-UT-PW-193-0090 | 325.4d | 243.2d |  |  | OK | 1.2.11.10 | PROC | PROC |
|  | 6 | **Gate Valves Direct Burried with Extension Spindle & Surface Box** |  |  | 2016-09-18 | 2017-02-12 |  |  |  |  |  |  |  |  |  |
| PR-Z4-UT-PW-194-0010 |  | RFQ - Gate Valves Direct Burried with Extension Spindle & Surface Box |  | 5.6d | 2016-09-18 | 2016-09-24 | PR-Z4-UT-PW-193-0010 SS, PROC-GE-GE-GE-0010 FS+14.4d | 135.6d | 0d |  |  | OK | 1.2.11.10 | PROC | PROC |
| PR-Z4-UT-PW-194-0020 |  | Material Submittal - Gate Valves Direct Burried with Extension Spindle & Surface Box |  | 8d | 2016-09-24 | 2016-10-03 | PR-Z4-UT-PW-194-0010 | 136d | 0d |  |  | OK | 1.2.11.10 | PROC | PROC |
| PR-Z4-UT-PW-194-0030 |  | Material Approval - Gate Valves Direct Burried with Extension Spindle & Surface Box |  | 11.2d | 2016-10-03 | 2016-10-16 | PR-Z4-UT-PW-194-0020 | 136d | 0d |  |  | OK | 1.2.11.10 | PROC | PROC |
| PR-Z4-UT-PW-194-0040 |  | Technical Evaluation - Gate Valves Direct Burried with Extension Spindle & Surface Box |  | 8d | 2016-10-17 | 2016-10-25 | PR-Z4-UT-PW-194-0030 | 136d | 0d |  |  | OK | 1.2.11.10 | PROC | PROC |
| PR-Z4-UT-PW-194-0050 |  | PO - Gate Valves Direct Burried with Extension Spindle & Surface Box |  | 11.2d | 2016-10-26 | 2016-11-08 | PR-Z4-UT-PW-194-0040 | 136d | 0d |  |  | OK | 1.2.11.10 | PROC | PROC |
| PR-Z4-UT-PW-194-0060 |  | NMR 601 - Gate Valves Direct Burried with Extension Spindle & Surface Box |  | 12d | 2016-11-08 | 2016-11-22 | PR-Z4-UT-PW-194-0050 | 136d | 0d |  |  | OK | 1.2.11.10 | PROC | PROC |
| PR-Z4-UT-PW-194-0070 |  | NMR 602 - Gate Valves Direct Burried with Extension Spindle & Surface Box |  | 12d | 2016-11-22 | 2016-12-06 | PR-Z4-UT-PW-194-0060 | 136d | 0d |  |  | OK | 1.2.11.10 | PROC | PROC |
| PR-Z4-UT-PW-194-0080 |  | Start of Material Delivery - Gate Valves Direct Burried with Extension Spindle & Surface Box | milestone | 0d | 2017-01-19 | 2017-01-19 | PR-Z4-UT-PW-194-0070 FS+38.4d | 136d | 0d |  |  | OK | 1.2.11.10 | PROC | PROC |
| PR-Z4-UT-PW-194-0090 |  | Complete Material Delivery - Gate Valves Direct Burried with Ext. Spindle & Surface Box |  | 12d | 2017-01-19 | 2017-02-02 | PR-Z4-UT-PW-194-0080 | 293.4d | 0d | Gate Valves Direct Buried with Extension Spindle & Surface Box [2 ea] | 9,603.58 | OK | 1.2.11.10 | PROC | PROC |
| PR-Z4-UT-PW-194-0100 |  | NMR 603 - Gate Valves Direct Burried with Extension Spindle & Surface Box |  | 8d | 2017-02-02 | 2017-02-12 | PR-Z4-UT-PW-194-0090 | 293.4d | 211.2d |  |  | OK | 1.2.11.10 | PROC | PROC |

Notes:
- PR-Z4-UT-PW-192-0090: Expenses: (New Expense Item) 91.08
- PR-Z4-UT-PW-193-0090: Expenses: (New Expense Item) 29323.1
- PR-Z4-UT-PW-194-0090: Expenses: (New Expense Item) 9603.58

| ID | WBS | Activity | Type | Duration | Start | Finish | Predecessors | Total float | Free float | Resources | Cost | Wajid | RPI_P2 - BOQ ITEMS | RPI_P2 - PROCUREMENT | RPI_P2 - PHASE |
| --- | --- | --- | --- | --- | --- | --- | --- | --- | --- | --- | --- | --- | --- | --- | --- |
|  | 7 | **Metallic Flanges, Pipe & Fittings for Fire Hydrants** |  |  | 2016-09-18 | 2017-01-30 |  |  |  |  |  |  |  |  |  |
| PR-Z4-UT-PW-195-0010 |  | RFQ - Metallic Flanges, Pipe & Fittings for Fire Hydrants |  | 5.6d | 2016-09-18 | 2016-09-24 | PROC-GE-GE-GE-0010 FS+16d, PR-Z4-UT-PW-194-0010 SS | 135.6d | 0d |  |  | OK | 1.2.11.10 | PROC | PROC |
| PR-Z4-UT-PW-195-0020 |  | Material Submittal - Metallic Flanges, Pipe & Fittings for Fire Hydrants |  | 8d | 2016-09-24 | 2016-10-03 | PR-Z4-UT-PW-195-0010 | 147.2d | 0d |  |  | OK | 1.2.11.10 | PROC | PROC |
| PR-Z4-UT-PW-195-0030 |  | Material Approval - Metallic Flanges, Pipe & Fittings for Fire Hydrants |  | 11.2d | 2016-10-03 | 2016-10-16 | PR-Z4-UT-PW-195-0020 | 147.2d | 0d |  |  | OK | 1.2.11.10 | PROC | PROC |
| PR-Z4-UT-PW-195-0040 |  | Technical Evaluation - Metallic Flanges, Pipe & Fittings for Fire Hydrants |  | 8d | 2016-10-17 | 2016-10-25 | PR-Z4-UT-PW-195-0030 | 147.2d | 0d |  |  | OK | 1.2.11.10 | PROC | PROC |
| PR-Z4-UT-PW-195-0050 |  | PO - Metallic Flanges, Pipe & Fittings for Fire Hydrants |  | 11.2d | 2016-10-26 | 2016-11-08 | PR-Z4-UT-PW-195-0040 | 147.2d | 0d |  |  | OK | 1.2.11.10 | PROC | PROC |
| PR-Z4-UT-PW-195-0060 |  | NMR 601 - Metallic Flanges, Pipe & Fittings for Fire Hydrants |  | 12d | 2016-11-08 | 2016-11-22 | PR-Z4-UT-PW-195-0050 | 147.2d | 0d |  |  | OK | 1.2.11.10 | PROC | PROC |
| PR-Z4-UT-PW-195-0070 |  | NMR 602 - Metallic Flanges, Pipe & Fittings for Fire Hydrants |  | 12d | 2016-11-22 | 2016-12-06 | PR-Z4-UT-PW-195-0060 | 147.2d | 0d |  |  | OK | 1.2.11.10 | PROC | PROC |
| PR-Z4-UT-PW-195-0080 |  | Start of Material Delivery - Metallic Flanges, Pipe & Fittings for Fire Hydrants | milestone | 0d | 2017-01-07 | 2017-01-07 | PR-Z4-UT-PW-195-0070 FS+27.2d | 147.2d | 0d |  |  | OK | 1.2.11.10 | PROC | PROC |
| PR-Z4-UT-PW-195-0090 |  | Complete Material Delivery - Metallic Flanges, Pipe & Fittings for Fire Hydrants |  | 12d | 2017-01-07 | 2017-01-21 | PR-Z4-UT-PW-195-0080 | 304.6d | 0d | Metallic Flanges, Pipes & Fittings (for Fire Hydrants) [2 Set] | 6,119.65 | OK | 1.2.11.10 | PROC | PROC |
| PR-Z4-UT-PW-195-0100 |  | NMR 603 - Metallic Flanges, Pipe & Fittings for Fire Hydrants |  | 8d | 2017-01-21 | 2017-01-30 | PR-Z4-UT-PW-195-0090 | 304.6d | 222.4d |  |  | OK | 1.2.11.10 | PROC | PROC |
|  | 8 | **Guard Post for Fire Hydrants** |  |  | 2016-09-25 | 2017-02-13 |  |  |  |  |  |  |  |  |  |
| PR-Z4-UT-PW-196-0010 |  | RFQ - Guard Post for Fire Hydrants |  | 12d | 2016-09-25 | 2016-10-09 | PROC-GE-GE-GE-0010 FS+16d, PR-Z4-UT-PW-195-0010 SS+6d | 135.6d | 0d |  |  | OK | 1.2.11.10 | PROC | PROC |
| PR-Z4-UT-PW-196-0020 |  | Material Submittal - Guard Post for Fire Hydrants |  | 8d | 2016-10-09 | 2016-10-18 | PR-Z4-UT-PW-196-0010 | 137.2d | 0d |  |  | OK | 1.2.11.10 | PROC | PROC |
| PR-Z4-UT-PW-196-0030 |  | Material Approval - Guard Post for Fire Hydrants |  | 11.2d | 2016-10-18 | 2016-10-31 | PR-Z4-UT-PW-196-0020 | 137.2d | 0d |  |  | OK | 1.2.11.10 | PROC | PROC |
| PR-Z4-UT-PW-196-0040 |  | Technical Evaluation - Guard Post for Fire Hydrants |  | 8d | 2016-10-31 | 2016-11-09 | PR-Z4-UT-PW-196-0030 | 137.2d | 0d |  |  | OK | 1.2.11.10 | PROC | PROC |
| PR-Z4-UT-PW-196-0050 |  | PO - Guard Post for Fire Hydrants |  | 11.2d | 2016-11-09 | 2016-11-22 | PR-Z4-UT-PW-196-0040 | 137.2d | 0d |  |  | OK | 1.2.11.10 | PROC | PROC |
| PR-Z4-UT-PW-196-0060 |  | NMR 601 - Guard Post for Fire Hydrants |  | 12d | 2016-11-22 | 2016-12-06 | PR-Z4-UT-PW-196-0050 | 137.2d | 0d |  |  | OK | 1.2.11.10 | PROC | PROC |
| PR-Z4-UT-PW-196-0070 |  | NMR 602 - Guard Post for Fire Hydrants |  | 12d | 2016-12-06 | 2016-12-20 | PR-Z4-UT-PW-196-0060 | 137.2d | 0d |  |  | OK | 1.2.11.10 | PROC | PROC |
| PR-Z4-UT-PW-196-0080 |  | Start of Material Delivery - Guard Post for Fire Hydrants | milestone | 0d | 2017-01-21 | 2017-01-21 | PR-Z4-UT-PW-196-0070 FS+27.2d | 137.2d | 0d |  |  | OK | 1.2.11.10 | PROC | PROC |
| PR-Z4-UT-PW-196-0090 |  | Complete Material Delivery - Guard Post for Fire Hydrants |  | 12d | 2017-01-21 | 2017-02-04 | PR-Z4-UT-PW-196-0080 | 292.2d | 0d | Guard Posts for Fire Hydrants [4 ea] | 2,561.71 | OK | 1.2.11.10 | PROC | PROC |
| PR-Z4-UT-PW-196-0100 |  | NMR 603 - Guard Post for Fire Hydrants |  | 8d | 2017-02-04 | 2017-02-13 | PR-Z4-UT-PW-196-0090 | 292.2d | 210d |  |  | OK | 1.2.11.10 | PROC | PROC |
|  | 9 | **Dismantling Joints - Valve Box Fittings** |  |  | 2016-09-25 | 2017-02-05 |  |  |  |  |  |  |  |  |  |
| PR-Z4-UT-PW-197-0010 |  | RFQ - Dismantling Joints ( Valve Box Fittings) |  | 5.6d | 2016-09-25 | 2016-10-01 | PR-Z4-UT-PW-196-0010 SS, PROC-GE-GE-GE-0010 FS+14.4d | 135.6d | 0d |  |  | OK | 1.2.11.10 | PROC | PROC |
| PR-Z4-UT-PW-197-0020 |  | Material Submittal - Dismantling Joints ( Valve Box Fittings) |  | 8d | 2016-10-01 | 2016-10-10 | PR-Z4-UT-PW-197-0010 | 140d | 0d |  |  | OK | 1.2.11.10 | PROC | PROC |
| PR-Z4-UT-PW-197-0030 |  | Material Approval - Dismantling Joints ( Valve Box Fittings) |  | 11.2d | 2016-10-10 | 2016-10-23 | PR-Z4-UT-PW-197-0020 | 140d | 0d |  |  | OK | 1.2.11.10 | PROC | PROC |
| PR-Z4-UT-PW-197-0040 |  | Technical Evaluation - Dismantling Joints ( Valve Box Fittings) |  | 8d | 2016-10-24 | 2016-11-01 | PR-Z4-UT-PW-197-0030 | 140d | 0d |  |  | OK | 1.2.11.10 | PROC | PROC |
| PR-Z4-UT-PW-197-0050 |  | PO - Dismantling Joints ( Valve Box Fittings) |  | 11.2d | 2016-11-02 | 2016-11-15 | PR-Z4-UT-PW-197-0040 | 140d | 0d |  |  | OK | 1.2.11.10 | PROC | PROC |
| PR-Z4-UT-PW-197-0060 |  | NMR 601 - Dismantling Joints ( Valve Box Fittings) |  | 12d | 2016-11-15 | 2016-11-29 | PR-Z4-UT-PW-197-0050 | 140d | 0d |  |  | OK | 1.2.11.10 | PROC | PROC |
| PR-Z4-UT-PW-197-0070 |  | NMR 602 - Dismantling Joints ( Valve Box Fittings) |  | 12d | 2016-11-29 | 2016-12-13 | PR-Z4-UT-PW-197-0060 | 140d | 0d |  |  | OK | 1.2.11.10 | PROC | PROC |
| PR-Z4-UT-PW-197-0080 |  | Start of Material Delivery - Dismantling Joints ( Valve Box Fittings) | milestone | 0d | 2017-01-12 | 2017-01-12 | PR-Z4-UT-PW-197-0070 FS+26.4d | 140d | 0d |  |  | OK | 1.2.11.10 | PROC | PROC |
| PR-Z4-UT-PW-197-0090 |  | Complete Material Delivery - Dismantling Joints ( Valve Box Fittings) |  | 12d | 2017-01-12 | 2017-01-26 | PR-Z4-UT-PW-197-0080 | 299.4d | 0d | Dismantling Joints - Valve Box Fittings [2 ea] | 15,361.74 | OK | 1.2.11.10 | PROC | PROC |
| PR-Z4-UT-PW-197-0100 |  | NMR 603 - Dismantling Joints ( Valve Box Fittings) |  | 8d | 2017-01-26 | 2017-02-05 | PR-Z4-UT-PW-197-0090 | 299.4d | 217.2d |  |  | OK | 1.2.11.10 | PROC | PROC |

Notes:
- PR-Z4-UT-PW-195-0090: Expenses: (New Expense Item) 6119.65
- PR-Z4-UT-PW-196-0090: Expenses: (New Expense Item) 2561.71
- PR-Z4-UT-PW-197-0090: Expenses: (New Expense Item) 15361.7

| ID | WBS | Activity | Type | Duration | Start | Finish | Predecessors | Total float | Free float | Resources | Cost | Wajid | RPI_P2 - BOQ ITEMS | RPI_P2 - PROCUREMENT | RPI_P2 - PHASE |
| --- | --- | --- | --- | --- | --- | --- | --- | --- | --- | --- | --- | --- | --- | --- | --- |
|  | 10 | **Gate Valves, Drain Valves** |  |  | 2016-09-25 | 2017-02-12 |  |  |  |  |  |  |  |  |  |
| PR-Z4-UT-PW-198-0010 |  | RFQ - Gate Valves, Drain Valves |  | 12d | 2016-09-25 | 2016-10-09 | PROC-GE-GE-GE-0010 FS+14.4d, PR-Z4-UT-PW-197-0010 SS | 135.6d | 0d |  |  | OK | 1.2.11.10 | PROC | PROC |
| PR-Z4-UT-PW-198-0020 |  | Material Submittal - Gate Valves, Drain Valves |  | 8d | 2016-10-09 | 2016-10-18 | PR-Z4-UT-PW-198-0010 | 135.6d | 0d |  |  | OK | 1.2.11.10 | PROC | PROC |
| PR-Z4-UT-PW-198-0030 |  | Material Approval - Gate Valves, Drain Valves |  | 11.2d | 2016-10-18 | 2016-10-31 | PR-Z4-UT-PW-198-0020 | 135.6d | 0d |  |  | OK | 1.2.11.10 | PROC | PROC |
| PR-Z4-UT-PW-198-0040 |  | Technical Evaluation - Gate Valves, Drain Valves |  | 8d | 2016-10-31 | 2016-11-09 | PR-Z4-UT-PW-198-0030 | 135.6d | 0d |  |  | OK | 1.2.11.10 | PROC | PROC |
| PR-Z4-UT-PW-198-0050 |  | PO - Gate Valves, Drain Valves |  | 11.2d | 2016-11-09 | 2016-11-22 | PR-Z4-UT-PW-198-0040 | 135.6d | 0d |  |  | OK | 1.2.11.10 | PROC | PROC |
| PR-Z4-UT-PW-198-0060 |  | NMR 601 - Gate Valves, Drain Valves |  | 12d | 2016-11-22 | 2016-12-06 | PR-Z4-UT-PW-198-0050 | 135.6d | 0d |  |  | OK | 1.2.11.10 | PROC | PROC |
| PR-Z4-UT-PW-198-0070 |  | NMR 602 - Gate Valves, Drain Valves |  | 12d | 2016-12-06 | 2016-12-20 | PR-Z4-UT-PW-198-0060 | 135.6d | 0d |  |  | OK | 1.2.11.10 | PROC | PROC |
| PR-Z4-UT-PW-198-0080 |  | Start of Material Delivery - Gate Valves, Drain Valves | milestone | 0d | 2017-01-21 | 2017-01-21 | PR-Z4-UT-PW-198-0070 FS+26.4d | 135.6d | 0d |  |  | OK | 1.2.11.10 | PROC | PROC |
| PR-Z4-UT-PW-198-0090 |  | Complete Material Delivery - Gate Valves, Drain Valves |  | 12d | 2017-01-21 | 2017-02-02 | PR-Z4-UT-PW-198-0080 | 293d | 0d | Gate Valves, Butterfly Valves, Drain Valves, Air Release Valves [3 ea] | 13,115.97 | OK | 1.2.11.10 | PROC | PROC |
| PR-Z4-UT-PW-198-0100 |  | NMR 603 - Gate Valves, Drain Valves |  | 8d | 2017-02-04 | 2017-02-12 | PR-Z4-UT-PW-198-0090 | 293d | 210.8d |  |  | OK | 1.2.11.10 | PROC | PROC |
|  | 11 | **DI Flanged Short Pipes, DI Tee, Puddle Sleeves, Nut & Bolts, Gaskets, Guages, Blind Flanges** |  |  | 2016-09-25 | 2017-02-05 |  |  |  |  |  |  |  |  |  |
| PR-Z4-UT-PW-199-0010 |  | RFQ - DI Flanged Short Pipes, DI Tee, Puddle Sleeves, Nut & Bolts, Gaskets... |  | 5.6d | 2016-09-25 | 2016-10-01 | PROC-GE-GE-GE-0010 FS+14.4d, PR-Z4-UT-PW-198-0010 SS | 140d | 0d |  |  | OK | 1.2.11.10 | PROC | PROC |
| PR-Z4-UT-PW-199-0020 |  | Material Submittal - DI Flanged Short Pipes, DI Tee, Puddle Sleeves, Nut & Bolts... |  | 8d | 2016-10-01 | 2016-10-10 | PR-Z4-UT-PW-199-0010 | 140d | 0d |  |  | OK | 1.2.11.10 | PROC | PROC |
| PR-Z4-UT-PW-199-0030 |  | Material Approval - DI Flanged Short Pipes, DI Tee, Puddle Sleeves, Nut & Bolts... |  | 11.2d | 2016-10-10 | 2016-10-23 | PR-Z4-UT-PW-199-0020 | 140d | 0d |  |  | OK | 1.2.11.10 | PROC | PROC |
| PR-Z4-UT-PW-199-0040 |  | Technical Evaluation - DI Flanged Short Pipes, DI Tee, Puddle Sleeves, Nut & Bolts... |  | 8d | 2016-10-24 | 2016-11-01 | PR-Z4-UT-PW-199-0030 | 140d | 0d |  |  | OK | 1.2.11.10 | PROC | PROC |
| PR-Z4-UT-PW-199-0050 |  | PO - DI Flanged Short Pipes, DI Tee, Puddle Sleeves, Nut & Bolts... |  | 11.2d | 2016-11-02 | 2016-11-15 | PR-Z4-UT-PW-199-0040 | 140d | 0d |  |  | OK | 1.2.11.10 | PROC | PROC |
| PR-Z4-UT-PW-199-0060 |  | NMR 601 - DI Flanged Short Pipes, DI Tee, Puddle Sleeves, Nut & Bolts... |  | 12d | 2016-11-15 | 2016-11-29 | PR-Z4-UT-PW-199-0050 | 140d | 0d |  |  | OK | 1.2.11.10 | PROC | PROC |
| PR-Z4-UT-PW-199-0070 |  | NMR 602 - DI Flanged Short Pipes, DI Tee, Puddle Sleeves, Nut & Bolts... |  | 12d | 2016-11-29 | 2016-12-13 | PR-Z4-UT-PW-199-0060 | 140d | 0d |  |  | OK | 1.2.11.10 | PROC | PROC |
| PR-Z4-UT-PW-199-0080 |  | Start of Material Delivery - DI Flanged Short Pipes, DI Tee, Puddle Sleeves, Nut & Bolts... | milestone | 0d | 2017-01-12 | 2017-01-12 | PR-Z4-UT-PW-199-0070 FS+26.4d | 140d | 0d |  |  | OK | 1.2.11.10 | PROC | PROC |
| PR-Z4-UT-PW-199-0090 |  | Complete Material Delivery - DI Flanged Short Pipes, DI Tee, Puddle Sleeves, Nut & Bolts... |  | 12d | 2017-01-12 | 2017-01-26 | PR-Z4-UT-PW-199-0080 | 299.4d | 0d | DI Flanged Short Pipes, DI Tee, Puddle Sleeves, Nuts & Bolts, Gasket [8 ea] | 9,287.63 | OK | 1.2.11.10 | PROC | PROC |
| PR-Z4-UT-PW-199-0100 |  | NMR 603 - DI Flanged Short Pipes, DI Tee, Puddle Sleeves, Nut & Bolts... |  | 8d | 2017-01-26 | 2017-02-05 | PR-Z4-UT-PW-199-0090 | 299.4d | 217.2d |  |  | OK | 1.2.11.10 | PROC | PROC |
|  | 12 | **Concrete for Valve Boxes** |  |  | 2016-08-30 | 2017-02-02 |  |  |  |  |  |  |  |  |  |
| PR-Z4-UT-PW-200-0010 |  | RFQ - Concrete for Valve Boxes |  | 12d | 2016-08-30 | 2016-09-18 | PROC-GE-GE-GE-0010 FS+18d | 301.4d | 0d |  |  | OK | 1.2.11.10 | PROC | PROC |
| PR-Z4-UT-PW-200-0020 |  | Material Submittal - Concrete for Valve Boxes |  | 8d | 2016-09-18 | 2016-09-27 | PR-Z4-UT-PW-200-0010 | 301.4d | 0d |  |  | OK | 1.2.11.10 | PROC | PROC |
| PR-Z4-UT-PW-200-0030 |  | Material Approval - Concrete for Valve Boxes |  | 11.2d | 2016-09-27 | 2016-10-10 | PR-Z4-UT-PW-200-0020 | 301.4d | 0d |  |  | OK | 1.2.11.10 | PROC | PROC |
| PR-Z4-UT-PW-200-0040 |  | Technical Evaluation - Concrete for Valve Boxes |  | 8d | 2016-10-10 | 2016-10-19 | PR-Z4-UT-PW-200-0030 | 301.4d | 0d |  |  | OK | 1.2.11.10 | PROC | PROC |
| PR-Z4-UT-PW-200-0050 |  | PO - Concrete for Valve Boxes |  | 11.2d | 2016-10-19 | 2016-11-01 | PR-Z4-UT-PW-200-0040 | 301.4d | 0d |  |  | OK | 1.2.11.10 | PROC | PROC |
| PR-Z4-UT-PW-200-0060 |  | NMR 601 - Concrete for Valve Boxes |  | 12d | 2016-11-01 | 2016-11-15 | PR-Z4-UT-PW-200-0050 | 301.4d | 0d |  |  | OK | 1.2.11.10 | PROC | PROC |
| PR-Z4-UT-PW-200-0070 |  | NMR 602 - Concrete for Valve Boxes |  | 12d | 2016-11-15 | 2016-11-29 | PR-Z4-UT-PW-200-0060 | 301.4d | 0d |  |  | OK | 1.2.11.10 | PROC | PROC |
| PR-Z4-UT-PW-200-0080 |  | Start of Material Delivery - Concrete for Valve Boxes | milestone | 0d | 2016-11-29 | 2016-11-29 | PR-Z4-UT-PW-200-0070 | 301.4d | 0d |  |  | OK | 1.2.11.10 | PROC | PROC |
| PR-Z4-UT-PW-200-0090 |  | Complete Material Delivery - Concrete for Valve Boxes |  | 48d | 2016-11-29 | 2017-01-24 | PR-Z4-UT-PW-200-0080 | 301.4d | 0d | Ready Mix Concrete [1 m³] | 478.19 | OK | 1.2.11.10 | PROC | PROC |
| PR-Z4-UT-PW-200-0100 |  | NMR 603 - Concrete for Valve Boxes |  | 8d | 2017-01-24 | 2017-02-02 | PR-Z4-UT-PW-200-0090 | 301.4d | 219.2d |  |  | OK | 1.2.11.10 | PROC | PROC |

Notes:
- PR-Z4-UT-PW-198-0090: Expenses: (New Expense Item) 13116
- PR-Z4-UT-PW-199-0090: Expenses: (New Expense Item) 9287.63
- PR-Z4-UT-PW-200-0090: Expenses: (New Expense Item) 478.19

| ID | WBS | Activity | Type | Duration | Start | Finish | Predecessors | Total float | Free float | Resources | Cost | Wajid | RPI_P2 - BOQ ITEMS | RPI_P2 - PROCUREMENT | RPI_P2 - PHASE |
| --- | --- | --- | --- | --- | --- | --- | --- | --- | --- | --- | --- | --- | --- | --- | --- |
|  | 2 | **Seawater System and related Material** |  |  | 2016-08-30 | 2017-03-16 |  |  |  |  |  |  |  |  |  |
|  | 1 | **RTR Pipes & Fittings including end caps** |  |  | 2016-08-30 | 2017-02-20 |  |  |  |  |  |  |  |  |  |
| PR-Z4-UT-SE-201-0010 |  | RFQ - RTR Pipes & Fittings including end caps |  | 12d | 2016-08-30 | 2016-09-18 | PROC-GE-GE-GE-0010 FS+18d | 159d | 0d |  |  | OK | 1.2.11.20 | PROC | PROC |
| PR-Z4-UT-SE-201-0020 |  | Material Submittal - RTR Pipes & Fittings including end caps |  | 8d | 2016-09-18 | 2016-09-27 | PR-Z4-UT-SE-201-0010 | 187.2d | 0d |  |  | OK | 1.2.11.20 | PROC | PROC |
| PR-Z4-UT-SE-201-0030 |  | Material Approval - RTR Pipes & Fittings including end caps |  | 11.2d | 2016-09-27 | 2016-10-10 | PR-Z4-UT-SE-201-0020 | 187.2d | 0d |  |  | OK | 1.2.11.20 | PROC | PROC |
| PR-Z4-UT-SE-201-0040 |  | Technical Evaluation - RTR Pipes & Fittings including end caps |  | 8d | 2016-10-10 | 2016-10-19 | PR-Z4-UT-SE-201-0030 | 187.2d | 0d |  |  | OK | 1.2.11.20 | PROC | PROC |
| PR-Z4-UT-SE-201-0050 |  | PO - RTR Pipes & Fittings including end caps |  | 11.2d | 2016-10-19 | 2016-11-01 | PR-Z4-UT-SE-201-0040 | 187.2d | 0d |  |  | OK | 1.2.11.20 | PROC | PROC |
| PR-Z4-UT-SE-201-0060 |  | NMR 601 - RTR Pipes & Fittings including end caps |  | 12d | 2016-11-01 | 2016-11-15 | PR-Z4-UT-SE-201-0050 | 187.2d | 0d |  |  | OK | 1.2.11.20 | PROC | PROC |
| PR-Z4-UT-SE-201-0070 |  | NMR 602 - RTR Pipes & Fittings including end caps |  | 12d | 2016-11-15 | 2016-11-29 | PR-Z4-UT-SE-201-0060 | 187.2d | 0d |  |  | OK | 1.2.11.20 | PROC | PROC |
| PR-Z4-UT-SE-201-0080 |  | Start of Material Delivery - RTR Pipes & Fittings including end caps | milestone | 0d | 2016-12-17 | 2016-12-17 | PR-Z4-UT-SE-201-0070 FS+15.2d | 187.2d | 0d |  |  | OK | 1.2.11.20 | PROC | PROC |
| PR-Z4-UT-SE-201-0090 |  | Complete Material Delivery - RTR Pipes & Fittings including end caps |  | 48d | 2016-12-17 | 2017-02-11 | PR-Z4-UT-SE-201-0080 | 286.2d | 0d | RTR Pipes & Fittings [282 Lm] | 83,718.35 | OK | 1.2.11.20 | PROC | PROC |
| PR-Z4-UT-SE-201-0100 |  | NMR 603 - RTR Pipes & Fittings including end caps |  | 8d | 2017-02-11 | 2017-02-20 | PR-Z4-UT-SE-201-0090 | 286.2d | 204d |  |  | OK | 1.2.11.20 | PROC | PROC |
|  | 7 | **Butterfly Valves, Air Release Valves, Gate Valves** |  |  | 2016-09-06 | 2017-03-16 |  |  |  |  |  |  |  |  |  |
| PR-Z4-UT-SE-202-0010 |  | RFQ - Butterfly Valves, Air Release Valves, Gate Valves |  | 5.6d | 2016-09-06 | 2016-09-17 | PROC-GE-GE-GE-0010 FS+14.4d, PR-Z4-UT-SE-201-0010 SS+6d | 159d | 0d |  |  | OK | 1.2.11.20 | PROC | PROC |
| PR-Z4-UT-SE-202-0020 |  | Material Submittal - Butterfly Valves, Air Release Valves, Gate Valves |  | 8d | 2016-09-17 | 2016-09-26 | PR-Z4-UT-SE-202-0010 | 159d | 0d |  |  | OK | 1.2.11.20 | PROC | PROC |
| PR-Z4-UT-SE-202-0030 |  | Material Approval - Butterfly Valves, Air Release Valves, Gate Valves |  | 11.2d | 2016-09-26 | 2016-10-09 | PR-Z4-UT-SE-202-0020 | 159d | 0d |  |  | OK | 1.2.11.20 | PROC | PROC |
| PR-Z4-UT-SE-202-0040 |  | Technical Evaluation - Butterfly Valves, Air Release Valves, Gate Valves |  | 8d | 2016-10-10 | 2016-10-18 | PR-Z4-UT-SE-202-0030 | 159d | 0d |  |  | OK | 1.2.11.20 | PROC | PROC |
| PR-Z4-UT-SE-202-0050 |  | PO - Butterfly Valves, Air Release Valves, Gate Valves |  | 11.2d | 2016-10-19 | 2016-11-01 | PR-Z4-UT-SE-202-0040 | 159d | 0d |  |  | OK | 1.2.11.20 | PROC | PROC |
| PR-Z4-UT-SE-202-0060 |  | NMR 601 - Butterfly Valves, Air Release Valves, Gate Valves |  | 12d | 2016-11-01 | 2016-11-15 | PR-Z4-UT-SE-202-0050 | 159d | 0d |  |  | OK | 1.2.11.20 | PROC | PROC |
| PR-Z4-UT-SE-202-0070 |  | NMR 602 - Butterfly Valves, Air Release Valves, Gate Valves |  | 12d | 2016-11-15 | 2016-11-29 | PR-Z4-UT-SE-202-0060 | 159d | 0d |  |  | OK | 1.2.11.20 | PROC | PROC |
| PR-Z4-UT-SE-202-0080 |  | Start of Material Delivery - Butterfly Valves, Air Release Valves, Gate Valves | milestone | 0d | 2017-02-07 | 2017-02-07 | PR-Z4-UT-SE-202-0070 FS+60d | 159d | 0d |  |  | OK | 1.2.11.20 | PROC | PROC |
| PR-Z4-UT-SE-202-0090 |  | Complete Material Delivery - Butterfly Valves, Air Release Valves, Gate Valves |  | 24d | 2017-02-07 | 2017-03-07 | PR-Z4-UT-SE-202-0080 | 265.8d | 0d | Gate Valves, Butterfly Valves, Drain Valves, Air Release Valves [11 ea] | 152,918.89 | OK | 1.2.11.20 | PROC | PROC |
| PR-Z4-UT-SE-202-0100 |  | NMR 603 - Butterfly Valves, Air Release Valves, Gate Valves |  | 8d | 2017-03-07 | 2017-03-16 | PR-Z4-UT-SE-202-0090 | 265.8d | 183.6d |  |  | OK | 1.2.11.20 | PROC | PROC |
|  | 8 | **Dismantling Joints** |  |  | 2016-09-06 | 2017-01-22 |  |  |  |  |  |  |  |  |  |
| PR-Z4-UT-SE-203-0010 |  | RFQ - Dismantling Joints |  | 12d | 2016-09-06 | 2016-09-25 | PROC-GE-GE-GE-0010 FS+14.4d, PR-Z4-UT-SE-202-0010 SS | 192.6d | 0d |  |  | OK | 1.2.11.20 | PROC | PROC |
| PR-Z4-UT-SE-203-0020 |  | Material Submittal - Dismantling Joints |  | 8d | 2016-09-25 | 2016-10-04 | PR-Z4-UT-SE-203-0010 | 192.6d | 0d |  |  | OK | 1.2.11.20 | PROC | PROC |
| PR-Z4-UT-SE-203-0030 |  | Material Approval - Dismantling Joints |  | 11.2d | 2016-10-04 | 2016-10-17 | PR-Z4-UT-SE-203-0020 | 192.6d | 0d |  |  | OK | 1.2.11.20 | PROC | PROC |
| PR-Z4-UT-SE-203-0040 |  | Technical Evaluation - Dismantling Joints |  | 8d | 2016-10-17 | 2016-10-26 | PR-Z4-UT-SE-203-0030 | 192.6d | 0d |  |  | OK | 1.2.11.20 | PROC | PROC |
| PR-Z4-UT-SE-203-0050 |  | PO - Dismantling Joints |  | 11.2d | 2016-10-26 | 2016-11-08 | PR-Z4-UT-SE-203-0040 | 192.6d | 0d |  |  | OK | 1.2.11.20 | PROC | PROC |
| PR-Z4-UT-SE-203-0060 |  | NMR 601 - Dismantling Joints |  | 12d | 2016-11-08 | 2016-11-22 | PR-Z4-UT-SE-203-0050 | 192.6d | 0d |  |  | OK | 1.2.11.20 | PROC | PROC |
| PR-Z4-UT-SE-203-0070 |  | NMR 602 - Dismantling Joints |  | 12d | 2016-11-22 | 2016-12-06 | PR-Z4-UT-SE-203-0060 | 192.6d | 0d |  |  | OK | 1.2.11.20 | PROC | PROC |
| PR-Z4-UT-SE-203-0080 |  | Start of Material Delivery - Dismantling Joints | milestone | 0d | 2017-01-07 | 2017-01-07 | PR-Z4-UT-SE-203-0070 FS+26.4d | 192.6d | 0d |  |  | OK | 1.2.11.20 | PROC | PROC |
| PR-Z4-UT-SE-203-0090 |  | Complete Material Delivery - Dismantling Joints |  | 6d | 2017-01-07 | 2017-01-12 | PR-Z4-UT-SE-203-0080 | 311d | 0d | Dismantling Joints - Valve Box Fittings [1 ea] | 19,762.76 | OK | 1.2.11.20 | PROC | PROC |
| PR-Z4-UT-SE-203-0100 |  | NMR 603 - Dismantling Joints |  | 8d | 2017-01-14 | 2017-01-22 | PR-Z4-UT-SE-203-0090 | 311d | 228.8d |  |  | OK | 1.2.11.20 | PROC | PROC |

Notes:
- PR-Z4-UT-SE-201-0090: Expenses: (New Expense Item) 83718.4
- PR-Z4-UT-SE-202-0090: Expenses: (New Expense Item) 152919
- PR-Z4-UT-SE-203-0090: Expenses: (New Expense Item) 19762.8

| ID | WBS | Activity | Type | Duration | Start | Finish | Predecessors | Total float | Free float | Resources | Cost | Wajid | RPI_P2 - BOQ ITEMS | RPI_P2 - PROCUREMENT | RPI_P2 - PHASE |
| --- | --- | --- | --- | --- | --- | --- | --- | --- | --- | --- | --- | --- | --- | --- | --- |
|  | 9 | **Puddle Sleeves, Metal Supports, Nut & Bolts, Pressure Indicators, Blind Flanges** |  |  | 2016-09-06 | 2017-01-19 |  |  |  |  |  |  |  |  |  |
| PR-Z4-UT-SE-204-0010 |  | RFQ - Puddle Sleeves, Metal Supports, Nut & Bolts, Pressure Indicators, Blind Flanges |  | 5.6d | 2016-09-06 | 2016-09-17 | PROC-GE-GE-GE-0010 FS+14.4d, PR-Z4-UT-SE-203-0010 SS | 313.8d | 0d |  |  | OK | 1.2.11.20 | PROC | PROC |
| PR-Z4-UT-SE-204-0020 |  | Material Submittal - Puddle Sleeves, Metal Supports, Nut & Bolts,... |  | 8d | 2016-09-17 | 2016-09-26 | PR-Z4-UT-SE-204-0010 | 313.8d | 0d |  |  | OK | 1.2.11.20 | PROC | PROC |
| PR-Z4-UT-SE-204-0030 |  | Material Approval - Puddle Sleeves, Metal Supports, Nut & Bolts,... |  | 11.2d | 2016-09-26 | 2016-10-09 | PR-Z4-UT-SE-204-0020 | 313.8d | 0d |  |  | OK | 1.2.11.20 | PROC | PROC |
| PR-Z4-UT-SE-204-0040 |  | Technical Evaluation - Puddle Sleeves, Metal Supports, Nut & Bolts,... |  | 8d | 2016-10-10 | 2016-10-18 | PR-Z4-UT-SE-204-0030 | 313.8d | 0d |  |  | OK | 1.2.11.20 | PROC | PROC |
| PR-Z4-UT-SE-204-0050 |  | PO - Puddle Sleeves, Metal Supports, Nut & Bolts,... |  | 11.2d | 2016-10-19 | 2016-11-01 | PR-Z4-UT-SE-204-0040 | 313.8d | 0d |  |  | OK | 1.2.11.20 | PROC | PROC |
| PR-Z4-UT-SE-204-0060 |  | NMR 601 - Puddle Sleeves, Metal Supports, Nut & Bolts,... |  | 4.8d | 2016-11-01 | 2016-11-06 | PR-Z4-UT-SE-204-0050 | 313.8d | 0d |  |  | OK | 1.2.11.20 | PROC | PROC |
| PR-Z4-UT-SE-204-0070 |  | NMR 602 - Puddle Sleeves, Metal Supports, Nut & Bolts,... |  | 4.8d | 2016-11-07 | 2016-11-12 | PR-Z4-UT-SE-204-0060 | 313.8d | 0d |  |  | OK | 1.2.11.20 | PROC | PROC |
| PR-Z4-UT-SE-204-0080 |  | Start of Material Delivery - Puddle Sleeves, Metal Supports, Nut & Bolts,... | milestone | 0d | 2016-12-13 | 2016-12-13 | PR-Z4-UT-SE-204-0070 FS+26.4d | 313.8d | 0d |  |  | OK | 1.2.11.20 | PROC | PROC |
| PR-Z4-UT-SE-204-0090 |  | Complete Material Delivery - Puddle Sleeves, Metal Supports, Nut & Bolts,... |  | 24d | 2016-12-13 | 2017-01-10 | PR-Z4-UT-SE-204-0080 | 313.8d | 0d | DI Flanged Short Pipes, DI Tee, Puddle Sleeves, Nuts & Bolts, Gasket [21 ea] | 36,094.53 | OK | 1.2.11.20 | PROC | PROC |
| PR-Z4-UT-SE-204-0100 |  | NMR 603 - Puddle Sleeves, Metal Supports, Nut & Bolts,... |  | 8d | 2017-01-10 | 2017-01-19 | PR-Z4-UT-SE-204-0090 | 313.8d | 231.6d |  |  | OK | 1.2.11.20 | PROC | PROC |
|  | 3 | **Sanitary Sewer System and related material** |  |  | 2016-09-18 | 2017-03-05 |  |  |  |  |  |  |  |  |  |
|  | 1 | **UPVC Pipes & Fittings** |  |  | 2016-09-18 | 2017-03-05 |  |  |  |  |  |  |  |  |  |
| PR-Z4-UT-SS-205-0010 |  | RFQ - UPVC Pipes & Fittings |  | 12d | 2016-09-18 | 2016-10-02 | PROC-GE-GE-GE-0010 FS+30d | 32.6d | 0d |  |  | OK | 1.2.11.30 | PROC | PROC |
| PR-Z4-UT-SS-205-0020 |  | Material Submittal - UPVC Pipes & Fittings |  | 8d | 2016-10-02 | 2016-10-11 | PR-Z4-UT-SS-205-0010 | 32.6d | 0d |  |  | OK | 1.2.11.30 | PROC | PROC |
| PR-Z4-UT-SS-205-0030 |  | Material Approval - UPVC Pipes & Fittings |  | 11.2d | 2016-10-11 | 2016-10-24 | PR-Z4-UT-SS-205-0020 | 32.6d | 0d |  |  | OK | 1.2.11.30 | PROC | PROC |
| PR-Z4-UT-SS-205-0040 |  | Technical Evaluation - UPVC Pipes & Fittings |  | 8d | 2016-10-24 | 2016-11-02 | PR-Z4-UT-SS-205-0030 | 32.6d | 0d |  |  | OK | 1.2.11.30 | PROC | PROC |
| PR-Z4-UT-SS-205-0050 |  | PO - UPVC Pipes & Fittings |  | 11.2d | 2016-11-02 | 2016-11-15 | PR-Z4-UT-SS-205-0040 | 32.6d | 0d |  |  | OK | 1.2.11.30 | PROC | PROC |
| PR-Z4-UT-SS-205-0060 |  | NMR 601 - UPVC Pipes & Fittings |  | 4.8d | 2016-11-15 | 2016-11-21 | PR-Z4-UT-SS-205-0050 | 32.6d | 0d |  |  | OK | 1.2.11.30 | PROC | PROC |
| PR-Z4-UT-SS-205-0070 |  | NMR 602 - UPVC Pipes & Fittings |  | 4.8d | 2016-11-21 | 2016-11-27 | PR-Z4-UT-SS-205-0060 | 32.6d | 0d |  |  | OK | 1.2.11.30 | PROC | PROC |
| PR-Z4-UT-SS-205-0080 |  | Start of Material Delivery - UPVC Pipes & Fittings | milestone | 0d | 2016-12-29 | 2016-12-29 | PR-Z4-UT-SS-205-0070 FS+28d | 32.6d | 0d |  |  | OK | 1.2.11.30 | PROC | PROC |
| PR-Z4-UT-SS-205-0090 |  | Complete Material Delivery - UPVC Pipes & Fittings |  | 48d | 2016-12-29 | 2017-02-23 | PR-Z4-UT-SS-205-0080 | 275.8d | 0d | UPVC Pipes & Fittings including Blind Flanges [746 Lm] | 61,903.29 | OK | 1.2.11.30 | PROC | PROC |
| PR-Z4-UT-SS-205-0100 |  | NMR 603 - UPVC Pipes & Fittings |  | 8d | 2017-02-23 | 2017-03-05 | PR-Z4-UT-SS-205-0090 | 275.8d | 193.6d |  |  | OK | 1.2.11.30 | PROC | PROC |
|  | 4 | **Irrigation System and related material** |  |  | 2016-09-18 | 2017-04-08 |  |  |  |  |  |  |  |  |  |
|  | 1 | **UPVC Pipes & Fittings** |  |  | 2016-09-18 | 2017-04-08 |  |  |  |  |  |  |  |  |  |
| PR-Z4-UT-IR-206-0010 |  | RFQ - UPVC Pipes & Fittings |  | 5.6d | 2016-09-18 | 2016-09-24 | PROC-GE-GE-GE-0010 FS+15.2d, PR-Z4-UT-SS-205-0010 SS | 223.6d | 0d |  |  | OK | 1.2.11.40 | PROC | PROC |
| PR-Z4-UT-IR-206-0020 |  | Material Submittal - UPVC Pipes & Fittings |  | 8d | 2016-09-24 | 2016-10-03 | PR-Z4-UT-IR-206-0010 | 223.6d | 0d |  |  | OK | 1.2.11.40 | PROC | PROC |
| PR-Z4-UT-IR-206-0030 |  | Material Approval - UPVC Pipes & Fittings |  | 11.2d | 2016-10-03 | 2016-10-16 | PR-Z4-UT-IR-206-0020 | 223.6d | 0d |  |  | OK | 1.2.11.40 | PROC | PROC |
| PR-Z4-UT-IR-206-0040 |  | Technical Evaluation - UPVC Pipes & Fittings |  | 8d | 2016-10-17 | 2016-10-25 | PR-Z4-UT-IR-206-0030 | 223.6d | 0d |  |  | OK | 1.2.11.40 | PROC | PROC |
| PR-Z4-UT-IR-206-0050 |  | PO - UPVC Pipes & Fittings |  | 11.2d | 2016-10-26 | 2016-11-08 | PR-Z4-UT-IR-206-0040 | 223.6d | 0d |  |  | OK | 1.2.11.40 | PROC | PROC |
| PR-Z4-UT-IR-206-0060 |  | NMR 601 - UPVC Pipes & Fittings |  | 4.8d | 2016-11-08 | 2016-11-13 | PR-Z4-UT-IR-206-0050 | 223.6d | 0d |  |  | OK | 1.2.11.40 | PROC | PROC |
| PR-Z4-UT-IR-206-0070 |  | NMR 602 - UPVC Pipes & Fittings |  | 4.8d | 2016-11-14 | 2016-11-19 | PR-Z4-UT-IR-206-0060 | 223.6d | 12d |  |  | OK | 1.2.11.40 | PROC | PROC |
| PR-Z4-UT-IR-206-0080 |  | Start of Material Delivery - UPVC Pipes & Fittings | milestone | 0d | 2017-01-04 | 2017-01-04 | PR-Z3-UT-PW-143-0080, PR-Z4-UT-IR-206-0070 FS+28d | 211.6d | 0d |  |  | OK | 1.2.11.40 | PROC | PROC |
| PR-Z4-UT-IR-206-0090 |  | Complete Material Delivery - UPVC Pipes & Fittings |  | 72d | 2017-01-04 | 2017-03-29 | PR-Z4-UT-IR-206-0080 | 246.2d | 0d | UPVC Pipes & Fittings including Blind Flanges [338 Lm] | 50,191.27 | OK | 1.2.11.40 | PROC | PROC |
| PR-Z4-UT-IR-206-0100 |  | NMR 603 - UPVC Pipes & Fittings |  | 8d | 2017-03-29 | 2017-04-08 | PR-Z4-UT-IR-206-0090 | 246.2d | 164d |  |  | OK | 1.2.11.40 | PROC | PROC |

Notes:
- PR-Z4-UT-SE-204-0090: Expenses: (New Expense Item) 36094.5
- PR-Z4-UT-SS-205-0090: Expenses: (New Expense Item) 61903.3
- PR-Z4-UT-IR-206-0090: Expenses: (New Expense Item) 50191.3

| ID | WBS | Activity | Type | Duration | Start | Finish | Predecessors | Total float | Free float | Resources | Cost | Wajid | RPI_P2 - BOQ ITEMS | RPI_P2 - PROCUREMENT | RPI_P2 - PHASE |
| --- | --- | --- | --- | --- | --- | --- | --- | --- | --- | --- | --- | --- | --- | --- | --- |
|  | 2 | **Direct Buried Valves** |  |  | 2016-09-18 | 2017-02-02 |  |  |  |  |  |  |  |  |  |
| PR-Z4-UT-IR-207-0010 |  | RFQ - Direct Buried Valves |  | 12d | 2016-09-18 | 2016-10-02 | PROC-GE-GE-GE-0010 FS+14.4d, PR-Z4-UT-IR-206-0010 SS | 301.4d | 0d |  |  | OK | 1.2.11.40 | PROC | PROC |
| PR-Z4-UT-IR-207-0020 |  | Material Submittal - Direct Buried Valves |  | 8d | 2016-10-02 | 2016-10-11 | PR-Z4-UT-IR-207-0010 | 301.4d | 0d |  |  | OK | 1.2.11.40 | PROC | PROC |
| PR-Z4-UT-IR-207-0030 |  | Material Approval - Direct Buried Valves |  | 11.2d | 2016-10-11 | 2016-10-24 | PR-Z4-UT-IR-207-0020 | 301.4d | 0d |  |  | OK | 1.2.11.40 | PROC | PROC |
| PR-Z4-UT-IR-207-0040 |  | Technical Evaluation - Direct Buried Valves |  | 8d | 2016-10-24 | 2016-11-02 | PR-Z4-UT-IR-207-0030 | 301.4d | 0d |  |  | OK | 1.2.11.40 | PROC | PROC |
| PR-Z4-UT-IR-207-0050 |  | PO - Direct Buried Valves |  | 11.2d | 2016-11-02 | 2016-11-15 | PR-Z4-UT-IR-207-0040 | 301.4d | 0d |  |  | OK | 1.2.11.40 | PROC | PROC |
| PR-Z4-UT-IR-207-0060 |  | NMR 601 - Direct Buried Valves |  | 4.8d | 2016-11-15 | 2016-11-21 | PR-Z4-UT-IR-207-0050 | 301.4d | 0d |  |  | OK | 1.2.11.40 | PROC | PROC |
| PR-Z4-UT-IR-207-0070 |  | NMR 602 - Direct Buried Valves |  | 4.8d | 2016-11-21 | 2016-11-27 | PR-Z4-UT-IR-207-0060 | 301.4d | 0d |  |  | OK | 1.2.11.40 | PROC | PROC |
| PR-Z4-UT-IR-207-0080 |  | Start of Material Delivery - Direct Buried Valves | milestone | 0d | 2017-01-10 | 2017-01-10 | PR-Z4-UT-IR-207-0070 FS+38.4d | 301.4d | 0d |  |  | OK | 1.2.11.40 | PROC | PROC |
| PR-Z4-UT-IR-207-0090 |  | Complete Material Delivery - Direct Buried Valves |  | 12d | 2017-01-10 | 2017-01-24 | PR-Z4-UT-IR-207-0080 | 301.4d | 0d | Direct Buried Valves & Gate Valves (200 mm dia.) for Irrigation [1 ea] | 6,391.09 | OK | 1.2.11.40 | PROC | PROC |
| PR-Z4-UT-IR-207-0100 |  | NMR 603 - Direct Buried Valves |  | 8d | 2017-01-24 | 2017-02-02 | PR-Z4-UT-IR-207-0090 | 301.4d | 219.2d |  |  | OK | 1.2.11.40 | PROC | PROC |
|  | 3 | **Dismantling Joints** |  |  | 2016-10-02 | 2017-01-26 |  |  |  |  |  |  |  |  |  |
| PR-Z4-UT-IR-208-0010 |  | RFQ - Dismantling Joints |  | 5.6d | 2016-10-02 | 2016-10-08 | PR-Z4-UT-IR-207-0010, PROC-GE-GE-GE-0010 FS+14.4d | 307.8d | 0d |  |  | OK | 1.2.11.40 | PROC | PROC |
| PR-Z4-UT-IR-208-0020 |  | Material Submittal - Dismantling Joints |  | 8d | 2016-10-08 | 2016-10-17 | PR-Z4-UT-IR-208-0010 | 307.8d | 0d |  |  | OK | 1.2.11.40 | PROC | PROC |
| PR-Z4-UT-IR-208-0030 |  | Material Approval - Dismantling Joints |  | 11.2d | 2016-10-17 | 2016-10-30 | PR-Z4-UT-IR-208-0020 | 307.8d | 0d |  |  | OK | 1.2.11.40 | PROC | PROC |
| PR-Z4-UT-IR-208-0040 |  | Technical Evaluation - Dismantling Joints |  | 8d | 2016-10-31 | 2016-11-08 | PR-Z4-UT-IR-208-0030 | 307.8d | 0d |  |  | OK | 1.2.11.40 | PROC | PROC |
| PR-Z4-UT-IR-208-0050 |  | PO - Dismantling Joints |  | 11.2d | 2016-11-09 | 2016-11-22 | PR-Z4-UT-IR-208-0040 | 307.8d | 0d |  |  | OK | 1.2.11.40 | PROC | PROC |
| PR-Z4-UT-IR-208-0060 |  | NMR 601 - Dismantling Joints |  | 4.8d | 2016-11-22 | 2016-11-27 | PR-Z4-UT-IR-208-0050 | 307.8d | 0d |  |  | OK | 1.2.11.40 | PROC | PROC |
| PR-Z4-UT-IR-208-0070 |  | NMR 602 - Dismantling Joints |  | 4.8d | 2016-11-28 | 2016-12-03 | PR-Z4-UT-IR-208-0060 | 307.8d | 0d |  |  | OK | 1.2.11.40 | PROC | PROC |
| PR-Z4-UT-IR-208-0080 |  | Start of Material Delivery - Dismantling Joints | milestone | 0d | 2017-01-03 | 2017-01-03 | PR-Z4-UT-IR-208-0070 FS+26.4d | 307.8d | 0d |  |  | OK | 1.2.11.40 | PROC | PROC |
| PR-Z4-UT-IR-208-0090 |  | Complete Material Delivery - Dismantling Joints |  | 12d | 2017-01-03 | 2017-01-17 | PR-Z4-UT-IR-208-0080 | 307.8d | 0d | Dismantling Joints - Valve Box Fittings [2 ea] | 15,330.1 | OK | 1.2.11.40 | PROC | PROC |
| PR-Z4-UT-IR-208-0100 |  | NMR 603 - Dismantling Joints |  | 8d | 2017-01-17 | 2017-01-26 | PR-Z4-UT-IR-208-0090 | 307.8d | 225.6d |  |  | OK | 1.2.11.40 | PROC | PROC |
|  | 4 | **DI Flanged Short Pipes, DI Tee, Puddle Sleeves, Nut & Bolts, Gaskets** |  |  | 2016-09-18 | 2017-01-26 |  |  |  |  |  |  |  |  |  |
| PR-Z4-UT-IR-209-0010 |  | RFQ - DI Flanged Short Pipes, DI Tee, Puddle Sleeves, Nut & Bolts, Gaskets |  | 5.6d | 2016-09-18 | 2016-09-24 | PROC-GE-GE-GE-0010 FS+30d | 307.8d | 0d |  |  | OK | 1.2.11.40 | PROC | PROC |
| PR-Z4-UT-IR-209-0020 |  | Material Submittal - DI Flanged Short Pipes, DI Tee, Puddle Sleeves, Nut & Bolts, Gaskets |  | 8d | 2016-09-24 | 2016-10-03 | PR-Z4-UT-IR-209-0010 | 307.8d | 0d |  |  | OK | 1.2.11.40 | PROC | PROC |
| PR-Z4-UT-IR-209-0030 |  | Material Approval - DI Flanged Short Pipes, DI Tee, Puddle Sleeves, Nut & Bolts, Gaskets |  | 11.2d | 2016-10-03 | 2016-10-16 | PR-Z4-UT-IR-209-0020 | 307.8d | 0d |  |  | OK | 1.2.11.40 | PROC | PROC |
| PR-Z4-UT-IR-209-0040 |  | Technical Evaluation - DI Flanged Short Pipes, DI Tee, Puddle Sleeves,... |  | 8d | 2016-10-17 | 2016-10-25 | PR-Z4-UT-IR-209-0030 | 307.8d | 0d |  |  | OK | 1.2.11.40 | PROC | PROC |
| PR-Z4-UT-IR-209-0050 |  | PO - DI Flanged Short Pipes, DI Tee, Puddle Sleeves,... |  | 11.2d | 2016-10-26 | 2016-11-08 | PR-Z4-UT-IR-209-0040 | 307.8d | 0d |  |  | OK | 1.2.11.40 | PROC | PROC |
| PR-Z4-UT-IR-209-0060 |  | NMR 601 - DI Flanged Short Pipes, DI Tee, Puddle Sleeves,... |  | 4.8d | 2016-11-08 | 2016-11-13 | PR-Z4-UT-IR-209-0050 | 307.8d | 0d |  |  | OK | 1.2.11.40 | PROC | PROC |
| PR-Z4-UT-IR-209-0070 |  | NMR 602 - DI Flanged Short Pipes, DI Tee, Puddle Sleeves,... |  | 4.8d | 2016-11-14 | 2016-11-19 | PR-Z4-UT-IR-209-0060 | 307.8d | 0d |  |  | OK | 1.2.11.40 | PROC | PROC |
| PR-Z4-UT-IR-209-0080 |  | Start of Material Delivery - DI Flanged Short Pipes, DI Tee, Puddle Sleeves,... | milestone | 0d | 2016-12-20 | 2016-12-20 | PR-Z4-UT-IR-209-0070 FS+26.4d | 307.8d | 0d |  |  | OK | 1.2.11.40 | PROC | PROC |
| PR-Z4-UT-IR-209-0090 |  | Complete Material Delivery - DI Flanged Short Pipes, DI Tee, Puddle Sleeves,... |  | 24d | 2016-12-20 | 2017-01-17 | PR-Z4-UT-IR-209-0080 | 307.8d | 0d | DI Flanged Short Pipes, DI Tee, Puddle Sleeves, Nuts & Bolts, Gasket [14 ea] | 15,983.41 | OK | 1.2.11.40 | PROC | PROC |
| PR-Z4-UT-IR-209-0100 |  | NMR 603 - DI Flanged Short Pipes, DI Tee, Puddle Sleeves,... |  | 8d | 2017-01-17 | 2017-01-26 | PR-Z4-UT-IR-209-0090 | 307.8d | 225.6d |  |  | OK | 1.2.11.40 | PROC | PROC |

Notes:
- PR-Z4-UT-IR-207-0090: Expenses: (New Expense Item) 6391.09
- PR-Z4-UT-IR-208-0090: Expenses: (New Expense Item) 15330.1
- PR-Z4-UT-IR-209-0090: Expenses: (New Expense Item) 15983.4

| ID | WBS | Activity | Type | Duration | Start | Finish | Predecessors | Total float | Free float | Resources | Cost | Wajid | RPI_P2 - BOQ ITEMS | RPI_P2 - PROCUREMENT | RPI_P2 - PHASE | RPI_P2 - CONSTRUCTION | RPI_P2 - ZONES | RPI_P2 - DISCIPLINE / WORK TYPE |
| --- | --- | --- | --- | --- | --- | --- | --- | --- | --- | --- | --- | --- | --- | --- | --- | --- | --- | --- |
|  | 5 | **Gate Valves** |  |  | 2016-09-18 | 2017-01-26 |  |  |  |  |  |  |  |  |  |  |  |  |
| PR-Z4-UT-IR-210-0010 |  | RFQ - Gate Valves |  | 5.6d | 2016-09-18 | 2016-09-24 | PR-Z4-UT-IR-209-0010 SS, PROC-GE-GE-GE-0010 FS+14.4d | 307.8d | 0d |  |  | OK | 1.2.11.40 | PROC | PROC |  |  |  |
| PR-Z4-UT-IR-210-0020 |  | Material Submittal - Gate Valves |  | 8d | 2016-09-24 | 2016-10-03 | PR-Z4-UT-IR-210-0010 | 307.8d | 0d |  |  | OK | 1.2.11.40 | PROC | PROC |  |  |  |
| PR-Z4-UT-IR-210-0030 |  | Material Approval - Gate Valves |  | 11.2d | 2016-10-03 | 2016-10-16 | PR-Z4-UT-IR-210-0020 | 307.8d | 0d |  |  | OK | 1.2.11.40 | PROC | PROC |  |  |  |
| PR-Z4-UT-IR-210-0040 |  | Technical Evaluation - Gate Valves |  | 8d | 2016-10-17 | 2016-10-25 | PR-Z4-UT-IR-210-0030 | 307.8d | 0d |  |  | OK | 1.2.11.40 | PROC | PROC |  |  |  |
| PR-Z4-UT-IR-210-0050 |  | PO - Gate Valves |  | 11.2d | 2016-10-26 | 2016-11-08 | PR-Z4-UT-IR-210-0040 | 307.8d | 0d |  |  | OK | 1.2.11.40 | PROC | PROC |  |  |  |
| PR-Z4-UT-IR-210-0060 |  | NMR 601 - Gate Valves |  | 4.8d | 2016-11-08 | 2016-11-13 | PR-Z4-UT-IR-210-0050 | 307.8d | 0d |  |  | OK | 1.2.11.40 | PROC | PROC |  |  |  |
| PR-Z4-UT-IR-210-0070 |  | NMR 602 - Gate Valves |  | 4.8d | 2016-11-14 | 2016-11-19 | PR-Z4-UT-IR-210-0060 | 307.8d | 0d |  |  | OK | 1.2.11.40 | PROC | PROC |  |  |  |
| PR-Z4-UT-IR-210-0080 |  | Start of Material Delivery - Gate Valves | milestone | 0d | 2017-01-03 | 2017-01-03 | PR-Z4-UT-IR-210-0070 FS+38.4d | 307.8d | 0d |  |  | OK | 1.2.11.40 | PROC | PROC |  |  |  |
| PR-Z4-UT-IR-210-0090 |  | Complete Material Delivery - Gate Valves |  | 12d | 2017-01-03 | 2017-01-17 | PR-Z4-UT-IR-210-0080 | 307.8d | 0d | Gate Valves, Butterfly Valves, Drain Valves, Air Release Valves [2 ea] | 12,782.16 | OK | 1.2.11.40 | PROC | PROC |  |  |  |
| PR-Z4-UT-IR-210-0100 |  | NMR 603 - Gate Valves |  | 8d | 2017-01-17 | 2017-01-26 | PR-Z4-UT-IR-210-0090 | 307.8d | 225.6d |  |  | OK | 1.2.11.40 | PROC | PROC |  |  |  |
|  | 5 | **Lighting Network System and related material** |  |  |  |  |  |  |  |  |  |  |  |  |  |  |  |  |
|  | 5 | **CONSTRUCTION** |  |  | 2016-08-09 | 2018-01-30 |  |  |  |  |  |  |  |  |  |  |  |  |
| CON-CON-CON-CON-0010 |  | Start of Construction | milestone | 0d | 2016-08-09 | 2016-08-09 | GE-CL-DL-GE-GE-0020 SS, GE-GE-GE-GE-GE-0010 | 0d |  |  |  | OK |  |  | CONS | CONS |  |  |
| CON-CON-CON-CON-0020 |  | Finish of Construction | milestone | 0d | 2018-01-30 | 2018-01-30 | CON-Z3-FS-03-TC-0040 FF, CON-Z3-UTIL-COM-0370, CON-Z3-SF-LS-GE-0020, CON-Z3-SL-LS-370, CON-Z3-AS-04-TC-0040, CON-Z3-FS-08-TC-350, CON-Z3-PS-05-TC-0030 FF, CON-Z3-PS-01-TC-0030, CON-Z3-FS-07-TC-0040, CO-PD-DM-JB-GE-0010, CON-Z4-UTIL-COM-0400, CON-Z4-UTIL-SIT-010, CON-Z3-UT-IRG-GE-050, CON-SZ3-SS-TIE-0020, CON-SZ3-SS-TIE-0040, CON-Z3-LS-SAND-20, CON-Z3-LS-SH-170, CON-Z3-LS-GRAS-30, CON-Z3-AS-02-TC-0010, CON-Z3-AS-02-TC-0020 FF, CON-Z3-SB-04-TC-0040 FF, CON-Z3-Tl01-TC-140, CON-Z3-FS-04-TC-0040, CO-PD-DM-AB-GE-0010, CO-PD-DM-DM-GE-0010, CO-PD-PC-PC-GE-0060, CO-PD-PC-PL-GE-0010, CO-PD-PC-PC-GE-0020, CON-Z4-LS9-TC-0060, CON-Z4-LS9-EW-0130, CON-Z3-UTIL-COM-1090, CON-Z3-UTIL-COM-1550, CON-Z3-UTIL-COM-1600, CON-Z3-LS-PT-0010, CON-Z3-LS-PT-0030, CON-Z3-LS-SAND-10, CON-Z3-LS-SH-220, CON-Z3-FS-08-TC-350 FF, CON-Z3-AS-01-TC-0040, CON-Z3-SB-01-TC-0040, CON-Z3-SB-01-TC-0040 FF, CON-Z3-SB-03-TC-0040 FF, CON-Z3-SB-03-TC-0040, CON-Z3-PS-05-TC-0030, CON-Z3-PS-04-TC-0030, CON-Z3-FS-02-TC-0040 FF, CON-Z3-FS-05-TC-0040, CON-Z3-FS-01-TC-0040 FF, CONC-Z4-UTIL-SL-10, CON-Z1-UTIL-COM-360, CO-PD-DM-RD-GE-0010, CO-PD-DM-PT-GE-0010, CO-PD-DM-DM-GE-0020, CON-CON-CON-CON-0010, CON-Z3-UTI-EL-SL-600, CON-Z3-UTI-RD-GE-010, CON-Z3-UT-IRG-GE-030, CON-SZ3-SS-TIE-0030, CON-Z3-LS-PT-0020, CON-Z3-LS-SAND-0010, CON-Z3-FS-08-TC-320, CON-Z3-FS-08-TC-340, CON-Z3-AS-03-TC-0040 FF, CON-Z3-AS-03-TC-0040, CON-Z3-Tl01-TC-0050, CON-Z3-PS-01-TC-0030 FF, CON-Z3-PS-02-TC-0030 FF, CON-Z3-FS-02-TC-0040, CON-Z3-FS-07-TC-0040 FF, CON-Z3-FS-06-TC-0040, CON-Z3-FS-04-TC-0040 FF, CO-PD-DM-DM-GE-0030, CO-PD-PC-PC-GE-0010, CON-GEN-MOB-MOB-100, CO-MO-SE-GE-GE-0180, RPI-Z3-LS11-TC-0060, CONC-Z3-UTIL-ELE-840, CON-SZ3-SEA-TIE-100, CON-Z3-LS-TR-170, CON-Z3-LS-GRAV-30, CON-Z3-LS-TR-230, CON-Z3-FS-08-TC-330, CON-Z3-SB-04-TC-0040, CON-Z3-PS-03-TC-0030, CON-Z1-UTIL-COM-0040, CON-SCH-MOB-MOB-30, CON-Z3-UTI-EL-SL-330, CON-Z3-UTIL-COM-1150, CON-Z3-UT-IRG-GE-020, CON-Z3-UT-IRG-GE-010, CON-Z3-LS-GRAV-10, CON-Z3-LS-GRAV-20, CON-Z3-LS-SAND-30, CON-Z3-LS-GRAS-0010, CON-Z3-FS-07-TC-270 FF, CON-Z3-AS-05-TC-0040, CON-Z3-AS-05-TC-0040 FF, CON-Z3-AS-02-TC-0020, CON-Z3-FS-07-TC-310 FF, CON-Z3-SB-02-TC-0040 FF, CON-Z3-FS-06-TC-0040 FF, CONC-Z4-UTIL-SL-010, CO-PD-DM-RB-GE-0010, CO-PD-PC-PC-GE-0070, CON-SZ3-SS-TIE-60, CON-Z3-UTI-EL-SL-400, CON-SZ3-SS-TIE-0010, CON-Z2-LS-PT-0010, CON-Z3-HRD-LS-430, CON-Z3-SL-LS-750, CON-Z3-SL-LS-560, CON-Z3-LS-GRAS-20, CON-Z3-LS-GRAV-0010, CON-Z3-AS-02-TC-0030, CON-Z3-PS-02-TC-0030, CON-Z3-FS-01-TC-0040, CO-PD-PC-SP-GE-0010, CO-PD-PC-MN-GE-0010, CO-PD-PC-PC-GE-0050, CO-PD-PC-PC-GE-0090, CO-PD-PC-PC-GE-0030, CON-GEN-MOB-MOB-040, CON-PEP-MOB-MOB-30, CON-Z3-UTIL-SIT-0010, CON-Z3-FS-03-TC-0040, CON-Z3-UTIL-COM-0460, CON-Z3-UTI-RD-R4-120, CON-Z3-UT-GRV-PL-250, CON-Z3-SF-LS-GE-0020 FF, CON-Z3-LS-GRAS-10, CON-Z3-FS-07-TC-270, CON-Z3-AS-01-TC-0040 FF, CON-Z3-FS-07-TC-310, CON-Z3-SB-02-TC-0040, CON-Z3-Tl01-TC-90, CON-Z3-Tl01-TC-0050 FF, CON-Z3-FS-05-TC-0040 FF, CO-PD-DM-DM-GE-0040, CO-PD-DM-DM-GE-0050, CO-PD-PC-PC-GE-0080, CO-PD-PC-PC-GE-0040, RPI-Z3-LS10-TC-0060, GE-UTIL-REL-GE-0270 | 0d |  |  |  | NOT |  |  | CONS | CONS |  |  |
|  | 7 | **MOBILIZATION** |  |  | 2016-08-09 | 2018-01-30 |  |  |  |  |  |  |  |  |  |  |  |  |
|  | 1 | **MOBILIZATION** |  |  | 2016-08-09 | 2018-01-30 |  |  |  |  |  |  |  |  |  |  |  |  |
|  | 1 | **Complete Construction Mobilization and Temporary Facilities** |  |  | 2016-08-09 | 2016-10-06 |  |  |  |  |  |  |  |  |  |  |  |  |
|  | 1 | **General Submittals & Approvals for Mobilization** |  |  | 2016-08-09 | 2016-09-05 |  |  |  |  |  |  |  |  |  |  |  |  |
| CON-GEN-MOB-MOB-010 |  | Submission & Approval of Layout Plans - Contractor's Site Offices & Facililties |  | 12d | 2016-08-09 | 2016-08-22 | CON-CON-CON-CON-0010 | 26.8d | 0d |  |  | OK | 1.3.1.10 |  | MOB | CONS | ZONE-3 | MOB |
| CON-GEN-MOB-MOB-020 |  | Submission & Approval of Layout Plans - Client's Site Offices & Facililties |  | 12d | 2016-08-23 | 2016-09-05 | CON-GEN-MOB-MOB-010 | 38.8d | 12d |  |  | OK | 1.3.1.10 |  | MOB | CONS | ZONE-3 | MOB |
|  | 2 | **Procurement For Mobilization** |  |  | 2016-08-11 | 2016-09-25 |  |  |  |  |  |  |  |  |  |  |  |  |
|  | 1 | **Client Offices (including AC)** |  |  | 2016-08-11 | 2016-09-25 |  |  |  |  |  |  |  |  |  |  |  |  |
| PR-Z3-GE-GE-211-0010 |  | RFQ - Client Offices (including AC) |  | 4d | 2016-08-11 | 2016-08-16 | PROC-GE-GE-GE-0010 FS+2.4d | 26.8d | 0d |  |  | OK | 1.3.1.10 |  | MOB | CONS | ZONE-3 | MOB |
| PR-Z3-GE-GE-211-0040 |  | Technical Evaluation - Client Offices (including AC) |  | 4d | 2016-08-16 | 2016-08-21 | PR-Z3-GE-GE-211-0010 | 46.8d | 0d |  |  | OK | 1.3.1.10 |  | MOB | CONS | ZONE-3 | MOB |
| PR-Z3-GE-GE-211-0050 |  | PO - Client Offices (including AC) |  | 5.6d | 2016-08-21 | 2016-08-27 | PR-Z3-GE-GE-211-0040 | 46.8d | 0d |  |  | OK | 1.3.1.10 |  | MOB | CONS | ZONE-3 | MOB |
| PR-Z3-GE-GE-211-0080 |  | Material Delivery - Client Offices (including AC) |  | 20d | 2016-08-28 | 2016-09-25 | PR-Z3-GE-GE-211-0050 | 46.8d | 20d |  |  | OK | 1.3.1.10 |  | MOB | CONS | ZONE-3 | MOB |

Notes:
- PR-Z4-UT-IR-210-0090: Expenses: (New Expense Item) 12782.2

| ID | WBS | Activity | Type | Duration | Start | Finish | Predecessors | Total float | Free float | Resources | Cost | Wajid | RPI_P2 - BOQ ITEMS | RPI_P2 - CONSTRUCTION | RPI_P2 - PHASE | RPI_P2 - ZONES | RPI_P2 - DISCIPLINE / WORK TYPE |
| --- | --- | --- | --- | --- | --- | --- | --- | --- | --- | --- | --- | --- | --- | --- | --- | --- | --- |
|  | 2 | **Furniture for Client Office** |  |  | 2016-08-11 | 2016-09-25 |  |  |  |  |  |  |  |  |  |  |  |
| PR-Z3-GE-GE-212-0010 |  | RFQ - Furniture for Client Office |  | 4d | 2016-08-11 | 2016-08-16 | PR-Z3-GE-GE-211-0010 SS | 26.8d | 0d |  |  | OK | 1.3.1.10 | CONS | MOB | ZONE-3 | MOB |
| PR-Z3-GE-GE-212-0040 |  | Technical Evaluation - Furniture for Client Office |  | 4d | 2016-08-16 | 2016-08-21 | PR-Z3-GE-GE-212-0010 | 26.8d | 0d |  |  | OK | 1.3.1.10 | CONS | MOB | ZONE-3 | MOB |
| PR-Z3-GE-GE-212-0050 |  | PO - Furniture for Client Office |  | 5.6d | 2016-08-21 | 2016-08-27 | PR-Z3-GE-GE-212-0040 | 26.8d | 0d |  |  | OK | 1.3.1.10 | CONS | MOB | ZONE-3 | MOB |
| PR-Z3-GE-GE-212-0080 |  | Material Delivery - Furniture for Client Office |  | 20d | 2016-08-28 | 2016-09-25 | PR-Z3-GE-GE-212-0050 | 26.8d | 0d |  |  | OK | 1.3.1.10 | CONS | MOB | ZONE-3 | MOB |
|  | 3 | **Parking Shades (10 Parkings) for Client Office** |  |  | 2016-08-11 | 2016-09-25 |  |  |  |  |  |  |  |  |  |  |  |
| PR-Z3-GE-GE-213-0010 |  | RFQ - Parking Shades (10 Parkings) for Client Office |  | 4d | 2016-08-11 | 2016-08-16 | PR-Z3-GE-GE-212-0010 SS | 26.8d | 0d |  |  | OK | 1.3.1.10 | CONS | MOB | ZONE-3 | MOB |
| PR-Z3-GE-GE-213-0040 |  | Technical Evaluation - Parking Shades (10 Parkings) for Client Office |  | 4d | 2016-08-16 | 2016-08-21 | PR-Z3-GE-GE-213-0010 | 26.8d | 0d |  |  | OK | 1.3.1.10 | CONS | MOB | ZONE-3 | MOB |
| PR-Z3-GE-GE-213-0050 |  | PO - Parking Shades (10 Parkings) for Client Office |  | 5.6d | 2016-08-21 | 2016-08-27 | PR-Z3-GE-GE-213-0040 | 26.8d | 0d |  |  | OK | 1.3.1.10 | CONS | MOB | ZONE-3 | MOB |
| PR-Z3-GE-GE-213-0080 |  | Material Delivery - Parking Shades (10 Parkings) for Client Office |  | 20d | 2016-08-28 | 2016-09-25 | PR-Z3-GE-GE-213-0050 | 26.8d | 0d |  |  | OK | 1.3.1.10 | CONS | MOB | ZONE-3 | MOB |
|  | 5 | **IT Req., Office Supplies & Consumables (Client Office)** |  |  | 2016-08-11 | 2016-09-25 |  |  |  |  |  |  |  |  |  |  |  |
| PR-Z3-GE-GE-214-0010 |  | RFQ - IT Req., Office Supplies & Consumables (Client Office) |  | 4d | 2016-08-11 | 2016-08-16 | PR-Z3-GE-GE-213-0010 SS | 26.8d | 0d |  |  | OK | 1.3.1.10 | CONS | MOB | ZONE-3 | MOB |
| PR-Z3-GE-GE-214-0040 |  | Technical Evaluation - IT Req., Office Supplies & Consumables (Client Office) |  | 4d | 2016-08-16 | 2016-08-21 | PR-Z3-GE-GE-214-0010 | 26.8d | 0d |  |  | OK | 1.3.1.10 | CONS | MOB | ZONE-3 | MOB |
| PR-Z3-GE-GE-214-0050 |  | PO - IT Req., Office Supplies & Consumables (Client Office) |  | 5.6d | 2016-08-21 | 2016-08-27 | PR-Z3-GE-GE-214-0040 | 26.8d | 0d |  |  | OK | 1.3.1.10 | CONS | MOB | ZONE-3 | MOB |
| PR-Z3-GE-GE-214-0080 |  | Material Delivery - IT Req., Office Supplies & Consumables (Client Office) |  | 20d | 2016-08-28 | 2016-09-25 | PR-Z3-GE-GE-214-0050 | 26.8d | 0d |  |  | OK | 1.3.1.10 | CONS | MOB | ZONE-3 | MOB |
|  | 3 | **Contractor's Site Offices & Support Facilities** |  |  | 2016-08-15 | 2016-10-06 |  |  |  |  |  |  |  |  |  |  |  |
| CON-GEN-MOB-MOB-040 |  | Installation of Site Fence & Gates |  | 30d | 2016-08-15 | 2016-09-24 | CON-GEN-MOB-MOB-010 SS+5d | 37.8d | 11d | Shuttering Carpenter [156 h]; Concrete Mason [156 h]; Common Labor / Helper [520 h]; Excavator [56 h]; Dump Truck [56 h]; Mobile Crane ( 25-60 Ton) [56 h]; Bobcat [56 h]; Concrete Transit Mixers [56 h]; Concrete Pump [56 h]; Asphalt Paver [56 h]; Asphalt Compactor / Roller [56 h]; Water Tanker [56 h] | 160,000 | OK | 1.3.1.10 | CONS | MOB | ZONE-3 | MOB |
| CON-GEN-MOB-MOB-030 |  | Site Survey Layout & Marking |  | 4d | 2016-08-23 | 2016-08-27 | CON-GEN-MOB-MOB-010 | 26.8d | 0d |  |  | OK | 1.3.1.10 | CONS | MOB | ZONE-3 | MOB |
| CON-GEN-MOB-MOB-080 |  | Installation of Contractor's Site Offices |  | 28d | 2016-08-28 | 2016-10-04 | CON-GEN-MOB-MOB-030 | 26.8d | 0d | Shuttering Carpenter [156 h]; Concrete Mason [156 h]; Plumber [104 h]; Electrician [104 h]; Mechanical Technician [52 h]; Welder [52 h]; Common Labor / Helper [520 h]; Scaffolder [104 h]; Plaster Mason [156 h]; Tiling Crew [104 h]; Painter [260 h]; RTR Pipe Crew [104 h]; Road Works Crew [104 h]; Finishing Work Crew [104 h]; Operator - Excavator [52 h]; Driver - Dump Truck [52 h]; Operator - Mobile Crane [52 h]; Operator - Bobcat [52 h]; Operator - Asphalt Compactor / Roller [52 h]; Operator - JCB [52 h]; Excavator [56 h]; Dump Truck [56 h]; Mobile Crane ( 25-60 Ton) [56 h]; Bobcat [56 h]; Concrete Transit Mixers [56 h]; Concrete Pump [56 h]; Asphalt Paver [56 h]; Asphalt Compactor / Roller [56 h]; Water Tanker [56 h]; Air-Compressor 300/900 CFM + Hummer [112 h]; JCB [56 h] | 672,000 | OK | 1.3.1.10 | CONS | MOB | ZONE-3 | MOB |
| CON-GEN-MOB-MOB-050 |  | Installation of Contractor's Site Support Facilities |  | 12d | 2016-09-19 | 2016-10-03 | CON-GEN-MOB-MOB-080 SS+15d | 34.8d | 3d | Driver - Dump Truck [156 h]; Operator - Mobile Crane [240 h]; Operator - Bobcat [480 h]; Shuttering Carpenter [780 h]; Concrete Mason [1560 h]; Plumber [780 h]; Electrician [1560 h]; Mechanical Technician [156 h]; Welder [312 h]; Common Labor / Helper [2340 h]; Scaffolder [624 h]; Plaster Mason [624 h]; Tiling Crew [156 h]; Painter [780 h]; RTR Pipe Crew [312 h]; Road Works Crew [312 h]; Finishing Work Crew [312 h]; Operator - Excavator [240 h] | 320,000 | OK | 1.3.1.10 | CONS | MOB | ZONE-3 | MOB |
| CON-GEN-MOB-MOB-060 |  | Parking Area & Parking Shades |  | 12d | 2016-09-22 | 2016-10-06 | CON-GEN-MOB-MOB-080 FF+2d, CON-GEN-MOB-MOB-050 SS | 31.8d | 5d | Shuttering Carpenter [624 h]; Concrete Mason [780 h]; Welder [156 h]; Common Labor / Helper [1560 h]; Operator - Mobile Crane [240 h]; Mobile Crane ( 25-60 Ton) [336 h] | 288,000 | OK | 1.3.1.10 | CONS | MOB | ZONE-3 | MOB |
| CON-GEN-MOB-MOB-090 |  | Installation of Laydown Yard , Storage Shed & Store |  | 12d | 2016-09-22 | 2016-10-06 | CON-GEN-MOB-MOB-080 FF+2d | 26.8d | 0d | Shuttering Carpenter [624 h]; Concrete Mason [624 h]; Plumber [468 h]; Electrician [312 h]; Mechanical Technician [156 h]; Welder [156 h]; Common Labor / Helper [1560 h]; Scaffolder [468 h]; Plaster Mason [468 h]; Tiling Crew [156 h]; Painter [468 h]; RTR Pipe Crew [156 h]; Operator - JCB [156 h]; Excavator [336 h]; Dump Truck [168 h]; Mobile Crane ( 25-60 Ton) [168 h]; Bobcat [336 h]; Concrete Transit Mixers [168 h]; Concrete Pump [168 h]; Asphalt Paver [168 h]; Asphalt Compactor / Roller [168 h]; Water Tanker [168 h]; Air-Compressor 300/900 CFM + Hummer [168 h]; JCB [168 h] | 480,000 | OK | 1.3.1.10 | CONS | MOB | ZONE-3 | MOB |
| CON-GEN-MOB-MOB-070 |  | IT Setup & Office Furnitures |  | 7d | 2016-09-28 | 2016-10-06 | CON-GEN-MOB-MOB-080 FF+2d, CON-GEN-MOB-MOB-060 SS | 26.8d | 0d | Electrician [182 h]; Mechanical Technician [91 h]; Common Labor / Helper [546 h] | 160,000 | OK | 1.3.1.10 | CONS | MOB | ZONE-3 | MOB |
| CON-GEN-MOB-MOB-100 |  | Completion of Mobilization Works & Temporary Facilities | milestone | 0d | 2016-10-06 | 2016-10-06 | CON-GEN-MOB-MOB-070, CON-GEN-MOB-MOB-040, CON-GEN-MOB-MOB-090 | 26.8d | 0d |  |  | OK | 1.3.1.10 | CONS | MOB | ZONE-3 | MOB |

Notes:
- CON-GEN-MOB-MOB-040: Expenses: (New Expense Item) 160000
- CON-GEN-MOB-MOB-080: Expenses: (New Expense Item) 672000
- CON-GEN-MOB-MOB-050: Expenses: (New Expense Item) 320000
- CON-GEN-MOB-MOB-060: Expenses: (New Expense Item) 288000
- CON-GEN-MOB-MOB-090: Expenses: (New Expense Item) 480000
- CON-GEN-MOB-MOB-070: Expenses: (New Expense Item) 160000

| ID | WBS | Activity | Duration | Start | Finish | Predecessors | Total float | Free float | Calendar | Resources | Cost | Wajid | RPI_P2 - BOQ ITEMS | RPI_P2 - CONSTRUCTION | RPI_P2 - PHASE | RPI_P2 - ZONES | RPI_P2 - DISCIPLINE / WORK TYPE |
| --- | --- | --- | --- | --- | --- | --- | --- | --- | --- | --- | --- | --- | --- | --- | --- | --- | --- |
|  | 4 | **Client Site Offices & Support Facilities** |  | 2016-09-25 | 2016-10-06 |  |  |  |  |  |  |  |  |  |  |  |  |
| CON-CLT-MOB-MOB-10 |  | Installation of Client Site Offices & Support Facilities | 10d | 2016-09-25 | 2016-10-06 | PR-Z3-GE-GE-213-0080, PR-Z3-GE-GE-214-0080, PR-Z3-GE-GE-211-0080 SS, CON-GEN-MOB-MOB-020, PR-Z3-GE-GE-212-0080 | 26.8d | 0d |  | Concrete Transit Mixers [154 h]; Concrete Pump [154 h]; Asphalt Paver [154 h]; Asphalt Compactor / Roller [154 h]; Water Tanker [154 h]; Air-Compressor 300/900 CFM + Hummer [154 h]; JCB [154 h]; Shuttering Carpenter [429 h]; Concrete Mason [429 h]; Plumber [429 h]; Electrician [572 h]; Mechanical Technician [143 h]; Welder [143 h]; Common Labor / Helper [715 h]; Scaffolder [286 h]; Plaster Mason [429 h]; Tiling Crew [143 h]; Painter [429 h]; RTR Pipe Crew [143 h]; Road Works Crew [143 h]; Finishing Work Crew [143 h]; Operator - Excavator [143 h]; Driver - Dump Truck [143 h]; Operator - Mobile Crane [143 h]; Operator - Bobcat [143 h]; Operator - Asphalt Compactor / Roller [143 h]; Operator - JCB [143 h]; Excavator [154 h]; Dump Truck [154 h]; Mobile Crane ( 25-60 Ton) [154 h]; Bobcat [154 h] | 1,120,000 | OK | 1.3.1.10 | CONS | MOB | ZONE-3 | MOB |
|  | 2 | **Approved Work Schedule** |  | 2016-08-09 | 2016-10-06 |  |  |  |  |  |  |  |  |  |  |  |  |
| CON-SCH-MOB-MOB-20 |  | Prepare & Submit - Work Schedule | 26d | 2016-08-09 | 2016-09-07 | CON-CON-CON-CON-0010 | 26.8d | 0d |  |  | 106,347.6 | OK | 1.3.1.20 | CONS | CONS |  |  |
| CON-SCH-MOB-MOB-30 |  | Approve - Work Schedule | 20d | 2016-09-08 | 2016-10-06 | CON-SCH-MOB-MOB-20 | 26.8d | 0d |  |  | 70,898.4 | OK | 1.3.1.20 | CONS | CONS |  |  |
|  | 3 | **Approved Contractor Project Execution Plan** |  | 2016-08-09 | 2016-10-06 |  |  |  |  |  |  |  |  |  |  |  |  |
| CON-PEP-MOB-MOB-20 |  | Prepare & Submit - Project Execution Plan | 26d | 2016-08-09 | 2016-09-07 | CON-CON-CON-CON-0010 | 26.8d | 0d |  |  | 159,521.4 | OK | 1.3.1.30 | CONS | CONS |  |  |
| CON-PEP-MOB-MOB-30 |  | Approve - Project Execution Plan | 20d | 2016-09-08 | 2016-10-06 | CON-PEP-MOB-MOB-20 | 26.8d | 0d |  |  | 106,347.6 | OK | 1.3.1.30 | CONS | CONS |  |  |
|  | 4 | **Security Services for all Zones** |  | 2016-08-09 | 2018-01-30 |  |  |  |  |  |  |  |  |  |  |  |  |
| CO-MO-SE-GE-GE-0010 |  | Security Services - (Month - 01) | 31d | 2016-08-09 | 2016-09-08 | GE-GE-GE-GE-GE-0010, CON-CON-CON-CON-0010 | 0d |  | RPI 2 - Thuwal (7 days Calendar) |  | 60,000 | OK | 1.3.1.40 | CONS | CONS |  |  |
| CO-MO-SE-GE-GE-0020 |  | Security Services - (Month - 02) | 30d | 2016-09-09 | 2016-10-08 | CO-MO-SE-GE-GE-0010 | 0d |  | RPI 2 - Thuwal (7 days Calendar) |  | 60,000 | OK | 1.3.1.40 | CONS | CONS |  |  |
| CO-MO-SE-GE-GE-0030 |  | Security Services - (Month - 03) | 31d | 2016-10-09 | 2016-11-08 | CO-MO-SE-GE-GE-0020 | 0d |  | RPI 2 - Thuwal (7 days Calendar) |  | 60,000 | OK | 1.3.1.40 | CONS | CONS |  |  |
| CO-MO-SE-GE-GE-0040 |  | Security Services - (Month - 04) | 30d | 2016-11-09 | 2016-12-08 | CO-MO-SE-GE-GE-0030 | 0d |  | RPI 2 - Thuwal (7 days Calendar) |  | 60,000 | OK | 1.3.1.40 | CONS | CONS |  |  |
| CO-MO-SE-GE-GE-0050 |  | Security Services - (Month - 05) | 31d | 2016-12-09 | 2017-01-08 | CO-MO-SE-GE-GE-0040 | 0d |  | RPI 2 - Thuwal (7 days Calendar) |  | 60,000 | OK | 1.3.1.40 | CONS | CONS |  |  |
| CO-MO-SE-GE-GE-0060 |  | Security Services - (Month - 06) | 31d | 2017-01-09 | 2017-02-08 | CO-MO-SE-GE-GE-0050 | 0d |  | RPI 2 - Thuwal (7 days Calendar) |  | 60,000 | OK | 1.3.1.40 | CONS | CONS |  |  |
| CO-MO-SE-GE-GE-0070 |  | Security Services - (Month - 07) | 28d | 2017-02-09 | 2017-03-08 | CO-MO-SE-GE-GE-0060 | 0d |  | RPI 2 - Thuwal (7 days Calendar) |  | 60,000 | OK | 1.3.1.40 | CONS | CONS |  |  |
| CO-MO-SE-GE-GE-0080 |  | Security Services - (Month - 08) | 31d | 2017-03-09 | 2017-04-08 | CO-MO-SE-GE-GE-0070 | 0d |  | RPI 2 - Thuwal (7 days Calendar) |  | 60,000 | OK | 1.3.1.40 | CONS | CONS |  |  |
| CO-MO-SE-GE-GE-0090 |  | Security Services - (Month - 09) | 30d | 2017-04-09 | 2017-05-08 | CO-MO-SE-GE-GE-0080 | 0d |  | RPI 2 - Thuwal (7 days Calendar) |  | 60,000 | OK | 1.3.1.40 | CONS | CONS |  |  |
| CO-MO-SE-GE-GE-0100 |  | Security Services - (Month - 10) | 31d | 2017-05-09 | 2017-06-08 | CO-MO-SE-GE-GE-0090 | 0d |  | RPI 2 - Thuwal (7 days Calendar) |  | 60,000 | OK | 1.3.1.40 | CONS | CONS |  |  |
| CO-MO-SE-GE-GE-0110 |  | Security Services - (Month - 11) | 30d | 2017-06-09 | 2017-07-08 | CO-MO-SE-GE-GE-0100 | 0d |  | RPI 2 - Thuwal (7 days Calendar) |  | 60,000 | OK | 1.3.1.40 | CONS | CONS |  |  |
| CO-MO-SE-GE-GE-0120 |  | Security Services - (Month - 12) | 31d | 2017-07-09 | 2017-08-08 | CO-MO-SE-GE-GE-0110 | 0d |  | RPI 2 - Thuwal (7 days Calendar) |  | 60,000 | OK | 1.3.1.40 | CONS | CONS |  |  |
| CO-MO-SE-GE-GE-0130 |  | Security Services - (Month - 13) | 31d | 2017-08-09 | 2017-09-08 | CO-MO-SE-GE-GE-0120 | 0d |  | RPI 2 - Thuwal (7 days Calendar) |  | 60,000 | OK | 1.3.1.40 | CONS | CONS |  |  |
| CO-MO-SE-GE-GE-0140 |  | Security Services - (Month - 14) | 30d | 2017-09-09 | 2017-10-08 | CO-MO-SE-GE-GE-0130 | 0d |  | RPI 2 - Thuwal (7 days Calendar) |  | 60,000 | OK | 1.3.1.40 | CONS | CONS |  |  |
| CO-MO-SE-GE-GE-0150 |  | Security Services - (Month - 15) | 31d | 2017-10-09 | 2017-11-08 | CO-MO-SE-GE-GE-0140 | 0d |  | RPI 2 - Thuwal (7 days Calendar) |  | 60,000 | OK | 1.3.1.40 | CONS | CONS |  |  |
| CO-MO-SE-GE-GE-0160 |  | Security Services - (Month - 16) | 30d | 2017-11-09 | 2017-12-08 | CO-MO-SE-GE-GE-0150 | 0d |  | RPI 2 - Thuwal (7 days Calendar) |  | 60,000 | OK | 1.3.1.40 | CONS | CONS |  |  |
| CO-MO-SE-GE-GE-0170 |  | Security Services - (Month - 17) | 31d | 2017-12-09 | 2018-01-08 | CO-MO-SE-GE-GE-0160 | 0d |  | RPI 2 - Thuwal (7 days Calendar) |  | 60,000 | OK | 1.3.1.40 | CONS | CONS |  |  |
| CO-MO-SE-GE-GE-0180 |  | Security Services - (Month - 18) | 22d | 2018-01-09 | 2018-01-30 | CO-MO-SE-GE-GE-0170 | 0d |  | RPI 2 - Thuwal (7 days Calendar) |  | 60,000 | OK | 1.3.1.40 | CONS | CONS |  |  |

Notes:
- CON-CLT-MOB-MOB-10: Expenses: (New Expense Item) 1120000
- CON-SCH-MOB-MOB-20: Expenses: (New Expense Item) 106348
- CON-SCH-MOB-MOB-30: Expenses: (New Expense Item) 70898.4
- CON-PEP-MOB-MOB-20: Expenses: (New Expense Item) 159521
- CON-PEP-MOB-MOB-30: Expenses: (New Expense Item) 106348
- CO-MO-SE-GE-GE-0010: Expenses: (New Expense Item) 60000
- CO-MO-SE-GE-GE-0020: Expenses: (New Expense Item) 60000
- CO-MO-SE-GE-GE-0030: Expenses: (New Expense Item) 60000
- CO-MO-SE-GE-GE-0040: Expenses: (New Expense Item) 60000
- CO-MO-SE-GE-GE-0050: Expenses: (New Expense Item) 60000
- CO-MO-SE-GE-GE-0060: Expenses: (New Expense Item) 60000
- CO-MO-SE-GE-GE-0070: Expenses: (New Expense Item) 60000
- CO-MO-SE-GE-GE-0080: Expenses: (New Expense Item) 60000
- CO-MO-SE-GE-GE-0090: Expenses: (New Expense Item) 60000
- CO-MO-SE-GE-GE-0100: Expenses: (New Expense Item) 60000
- CO-MO-SE-GE-GE-0110: Expenses: (New Expense Item) 60000
- CO-MO-SE-GE-GE-0120: Expenses: (New Expense Item) 60000
- CO-MO-SE-GE-GE-0130: Expenses: (New Expense Item) 60000
- CO-MO-SE-GE-GE-0140: Expenses: (New Expense Item) 60000
- CO-MO-SE-GE-GE-0150: Expenses: (New Expense Item) 60000
- CO-MO-SE-GE-GE-0160: Expenses: (New Expense Item) 60000
- CO-MO-SE-GE-GE-0170: Expenses: (New Expense Item) 60000
- CO-MO-SE-GE-GE-0180: Expenses: (New Expense Item) 60000

| ID | WBS | Activity | Duration | Start | Finish | Predecessors | Total float | Free float | Resources | Cost | Wajid | RPI_P2 - BOQ ITEMS | RPI_P2 - CONSTRUCTION | RPI_P2 - PHASE | RPI_P2 - ZONES | RPI_P2 - DISCIPLINE / WORK TYPE | RPI_P2 - UTILITY NETWORK |
| --- | --- | --- | --- | --- | --- | --- | --- | --- | --- | --- | --- | --- | --- | --- | --- | --- | --- |
|  | 2 | **CONSTRUCTION FOR ZONE - 1 & 2** |  | 2017-03-12 | 2017-10-28 |  |  |  |  |  |  |  |  |  |  |  |  |
|  | 1 | **UTILITIES & SERVICES WORKS** |  | 2017-03-12 | 2017-10-28 |  |  |  |  |  |  |  |  |  |  |  |  |
|  | 1 | **Communication & Security System** |  | 2017-03-12 | 2017-10-28 |  |  |  |  |  |  |  |  |  |  |  |  |
|  | 1 | **FOC and Copper Cable System** |  | 2017-03-12 | 2017-09-27 |  |  |  |  |  |  |  |  |  |  |  |  |
| CON-Z1-UTIL-COM-0010 |  | Installation of Sub-Ducts for FOC | 30d | 2017-03-12 | 2017-04-16 | GE-DWG-ENG-ENG-0040, CON-CON-CON-CON-0010 SS+180d, PR-MT-Z1-LC-13-0090 | 4.8d | 0d | Electrician [1800 h] |  | OK | 1.3.2.10 | CONS | CONS | ZONE-1&2 | COMM | COMM |
| CON-Z1-UTIL-COM-0020 |  | Installation of FOC and Copper Cables in Zone 1 & 2 | 26d | 2017-06-25 | 2017-07-30 | PR-MT-Z1-LC-01-0090, CON-Z1-UTIL-COM-0010 FS+60d | 4.8d | 0d | Electrician [520 h]; LC Crew [260 h] | 389,295.16 | OK | 1.3.2.10 | CONS | CONS | ZONE-1&2 | COMM | COMM |
| CON-Z1-UTIL-COM-0030 |  | Splicing and Termination of FOC and Copper Cables in Zone 1 & 2 | 26d | 2017-07-23 | 2017-08-22 | PR-MT-Z1-LC-02-0090, CON-Z1-UTIL-COM-0020 SS+20d | 12.8d | 0d | Electrician [520 h]; LC Crew [520 h] | 155,718.07 | OK | 1.3.2.10 | CONS | CONS | ZONE-1&2 | COMM | COMM |
| CON-Z1-UTIL-COM-0040 |  | Testing and Precommissioning of FOC and Copper Cables in Zone 1 & 2 | 26d | 2017-08-22 | 2017-09-27 | CON-Z1-UTIL-COM-0030 | 12.8d | 8d | Electrician [2704 h]; LC Crew [676 h] | 233,577.1 | OK | 1.3.2.10 | CONS | CONS | ZONE-1&2 | COMM | COMM |
|  | 2 | **Code Blue System** |  | 2017-06-25 | 2017-10-24 |  |  |  |  |  |  |  |  |  |  |  |  |
|  | 1 | **Code Blue Cable Works** |  | 2017-06-25 | 2017-10-21 |  |  |  |  |  |  |  |  |  |  |  |  |
| CON-Z1-UTIL-COM-050 |  | Excavation for Code Blue LV Cable Trench | 26d | 2017-06-25 | 2017-07-30 | CON-Z1-UTIL-COM-0020 SS | 4.8d | 0d | JCB [520 h]; Operator - JCB [520 h] | 39,369.74 | OK | 1.3.2.10 | CONS | CONS | ZONE-1&2 | COMM | COMM |
| CON-Z1-UTIL-COM-060 |  | Compaction and Sand bedding for Code Blue LV Cable Trench | 8d | 2017-07-30 | 2017-08-08 | CON-Z1-UTIL-COM-050 | 7.8d | 0d | Common Labor / Helper [80 h]; Operator - Roller-Compactor (2~10 Ton) [104 h]; Driver - Water Tanker [104 h]; Operator - JCB [104 h]; Roller-Compactor (2~10 Ton) [112 h]; Water Tanker [112 h]; JCB [112 h] | 39,369.74 | OK | 1.3.2.10 | CONS | CONS | ZONE-1&2 | COMM | COMM |
| CON-Z1-UTIL-COM-070 |  | Installation of Code Blue LV Cables | 26d | 2017-08-08 | 2017-09-12 | PR-MT-Z1-LC-07-0090, CON-Z1-UTIL-COM-060 | 7.8d | 0d | Electrician [2028 h]; LC Crew [1352 h] | 118,109.22 | OK | 1.3.2.10 | CONS | CONS | ZONE-1&2 | COMM | COMM |
| CON-Z1-UTIL-COM-080 |  | Sand Backfillling for Code Blue LV Cable Trench | 8d | 2017-09-12 | 2017-09-21 | PR-MT-Z1-LC-08-0090, CON-Z1-UTIL-COM-070 | 7.8d | 0d | Common Labor / Helper [624 h]; Operator - Roller-Compactor (2~10 Ton) [104 h]; Driver - Water Tanker [104 h]; Operator - JCB [104 h]; Roller-Compactor (2~10 Ton) [112 h]; Water Tanker [112 h]; JCB [112 h] | 39,369.74 | OK | 1.3.2.10 | CONS | CONS | ZONE-1&2 | COMM | COMM |
| CON-Z1-UTIL-COM-090 |  | Instalation of Red Tiles and Warning Tape | 12d | 2017-09-21 | 2017-10-07 | PR-MT-Z1-LC-10-0090, CON-Z1-UTIL-COM-080, PR-MT-Z1-LC-09-0090 | 7.8d | 0d | Common Labor / Helper [780 h] | 78,739.48 | OK | 1.3.2.10 | CONS | CONS | ZONE-1&2 | COMM | COMM |
| CON-Z1-UTIL-COM-100 |  | Final Backfilling | 12d | 2017-10-07 | 2017-10-21 | CON-Z1-UTIL-COM-090 | 7.8d | 0d | Common Labor / Helper [260 h]; Operator - Roller-Compactor (2~10 Ton) [65 h]; Driver - Water Tanker [65 h]; Operator - JCB [65 h] | 78,739.48 | OK | 1.3.2.10 | CONS | CONS | ZONE-1&2 | COMM | COMM |
|  | 2 | **Code Blue Pedestals (8 No.)** |  | 2017-07-30 | 2017-10-24 |  |  |  |  |  |  |  |  |  |  |  |  |
| CON-Z1-UTIL-COM-110 |  | Excavation for foundations of Code Blue Pedestals | 4d | 2017-07-30 | 2017-08-03 | CON-Z1-UTIL-COM-050 | 4.8d | 0d | JCB [56 h]; Operator - JCB [52 h] | 52,492.99 | OK | 1.3.2.10 | CONS | CONS | ZONE-1&2 | COMM | COMM |
| CON-Z1-UTIL-COM-120 |  | Compaction and Lean Concrete | 4d | 2017-08-03 | 2017-08-08 | CON-Z1-UTIL-COM-110 | 36.8d | 0d | Concrete Mason [390 h]; Common Labor / Helper [260 h] | 26,246.49 | OK | 1.3.2.10 | CONS | CONS | ZONE-1&2 | COMM | COMM |
| CON-Z1-UTIL-COM-130 |  | Installation of Code Blue Concrete Foundations including Anchor Bolts | 8d | 2017-08-08 | 2017-08-17 | CON-Z1-UTIL-COM-120 | 36.8d | 0d | Steel Fixer [390 h]; Shuttering Carpenter [390 h]; Concrete Mason [390 h]; Common Labor / Helper [624 h] | 52,492.99 | OK | 1.3.2.10 | CONS | CONS | ZONE-1&2 | COMM | COMM |
| CON-Z1-UTIL-COM-140 |  | Installation of Code Blue Pedestals | 6d | 2017-08-17 | 2017-08-24 | PR-MT-Z1-LC-06-0090, CON-Z1-UTIL-COM-130 | 36.8d | 0d | Common Labor / Helper [468 h]; Specialist Works Crew [390 h] | 52,492.99 | OK | 1.3.2.10 | CONS | CONS | ZONE-1&2 | COMM | COMM |
| CON-Z1-UTIL-COM-150 |  | Termination of Cables | 6d | 2017-08-24 | 2017-09-05 | CON-Z1-UTIL-COM-140 | 36.8d | 29d | Electrician [468 h]; LC Crew [234 h] | 26,246.49 | OK | 1.3.2.10 | CONS | CONS | ZONE-1&2 | COMM | COMM |
| CON-Z1-UTIL-COM-160 |  | Testing and Precommissioning of Code Blue System | 12d | 2017-10-10 | 2017-10-24 | CON-Z1-UTIL-COM-150, CON-Z1-UTIL-COM-100 SS+3d | 7.8d | 7.4d | LC Crew [130 h] | 52,492.99 | OK | 1.3.2.10 | CONS | CONS | ZONE-1&2 | COMM | COMM |
|  | 3 | **CCTV Works** |  | 2017-07-30 | 2017-10-28 |  |  |  |  |  |  |  |  |  |  |  |  |
|  | 1 | **External Cabling For CCTV System** |  | 2017-07-30 | 2017-10-23 |  |  |  |  |  |  |  |  |  |  |  |  |
|  | 1 | **LV Power Cables (Direct Burried) For Camera** |  | 2017-07-30 | 2017-10-23 |  |  |  |  |  |  |  |  |  |  |  |  |
| CON-Z1-UTIL-COM-170 |  | Excavation for LV Cable Trench for Camera | 16d | 2017-07-30 | 2017-08-17 | CON-Z1-UTIL-COM-110 SS | 4.8d | 0d | JCB [160 h]; Operator - JCB [160 h] | 13,123.25 | OK | 1.3.2.10 | CONS | CONS | ZONE-1&2 | COMM | COMM |
| CON-Z1-UTIL-COM-180 |  | Compaction and Sand bedding for LV Cable Trench for Camera | 16d | 2017-08-17 | 2017-09-10 | CON-Z1-UTIL-COM-170 | 4.8d | 0d | Common Labor / Helper [1040 h]; Operator - Roller-Compactor (2~10 Ton) [208 h]; Driver - Water Tanker [208 h]; Operator - JCB [208 h]; Roller-Compactor (2~10 Ton) [224 h]; Water Tanker [224 h]; JCB [224 h] | 13,123.25 | OK | 1.3.2.10 | CONS | CONS | ZONE-1&2 | COMM | COMM |
| CON-Z1-UTIL-COM-190 |  | Instalaltion of LV Cables for Camera | 12d | 2017-09-10 | 2017-09-25 | CON-Z1-UTIL-COM-180 | 4.8d | 0d | LC Crew [312 h] | 26,246.49 | OK | 1.3.2.10 | CONS | CONS | ZONE-1&2 | COMM | COMM |
| CON-Z1-UTIL-COM-200 |  | Soft Sandfilling for Code Blue LV Cable Trench | 12d | 2017-09-25 | 2017-10-09 | CON-Z1-UTIL-COM-190 | 4.8d | 0d | Common Labor / Helper [260 h]; Operator - Roller-Compactor (2~10 Ton) [65 h]; Driver - Water Tanker [65 h]; Operator - JCB [65 h]; Roller-Compactor (2~10 Ton) [70 h]; Water Tanker [70 h]; JCB [70 h] | 6,561.62 | OK | 1.3.2.10 | CONS | CONS | ZONE-1&2 | COMM | COMM |
| CON-Z1-UTIL-COM-210 |  | Instalation of Red Tiles and Warning Tape | 12d | 2017-09-28 | 2017-10-12 | CON-Z1-UTIL-COM-200 SS+3d | 4.8d | 0d | Common Labor / Helper [260 h] | 26,246.49 | OK | 1.3.2.10 | CONS | CONS | ZONE-1&2 | COMM | COMM |
| CON-Z1-UTIL-COM-220 |  | Final Backfilling | 18d | 2017-10-02 | 2017-10-23 | CON-Z1-UTIL-COM-210 SS+3d | 4.8d | 0d | Common Labor / Helper [260 h]; Operator - Roller-Compactor (2~10 Ton) [65 h]; Driver - Water Tanker [65 h]; Operator - JCB [65 h]; Roller-Compactor (2~10 Ton) [70 h]; Water Tanker [70 h]; JCB [70 h] | 19,684.87 | OK | 1.3.2.10 | CONS | CONS | ZONE-1&2 | COMM | COMM |
| CON-Z1-UTIL-COM-370 |  | Testing and Precommissioning of LV Cables for Camera | 12d | 2017-10-04 | 2017-10-18 | CON-Z1-UTIL-COM-220 SS+2d | 4.8d | 0d | LC Crew [104 h] | 26,246.49 | OK | 1.3.2.10 | CONS | CONS | ZONE-1&2 | COMM | COMM |

Notes:
- CON-Z1-UTIL-COM-0010: Expenses: (New Expense Item) 0
- CON-Z1-UTIL-COM-0020: Expenses: (New Expense Item) 389295
- CON-Z1-UTIL-COM-0030: Expenses: (New Expense Item) 155718
- CON-Z1-UTIL-COM-0040: Expenses: (New Expense Item) 233577
- CON-Z1-UTIL-COM-050: Expenses: (New Expense Item) 39369.7
- CON-Z1-UTIL-COM-060: Expenses: (New Expense Item) 39369.7
- CON-Z1-UTIL-COM-070: Expenses: (New Expense Item) 118109
- CON-Z1-UTIL-COM-080: Expenses: (New Expense Item) 39369.7
- CON-Z1-UTIL-COM-090: Expenses: (New Expense Item) 78739.5
- CON-Z1-UTIL-COM-100: Expenses: (New Expense Item) 78739.5
- CON-Z1-UTIL-COM-110: Expenses: (New Expense Item) 52493
- CON-Z1-UTIL-COM-120: Expenses: (New Expense Item) 26246.5
- CON-Z1-UTIL-COM-130: Expenses: (New Expense Item) 52493
- CON-Z1-UTIL-COM-140: Expenses: (New Expense Item) 52493
- CON-Z1-UTIL-COM-150: Expenses: (New Expense Item) 26246.5
- CON-Z1-UTIL-COM-160: Expenses: (New Expense Item) 52493
- CON-Z1-UTIL-COM-170: Expenses: (New Expense Item) 13123.2
- CON-Z1-UTIL-COM-180: Expenses: (New Expense Item) 13123.2
- CON-Z1-UTIL-COM-190: Expenses: (New Expense Item) 26246.5
- CON-Z1-UTIL-COM-200: Expenses: (New Expense Item) 6561.62
- CON-Z1-UTIL-COM-210: Expenses: (New Expense Item) 26246.5
- CON-Z1-UTIL-COM-220: Expenses: (New Expense Item) 19684.9
- CON-Z1-UTIL-COM-370: Expenses: (New Expense Item) 26246.5

| ID | WBS | Activity | Duration | Start | Finish | Predecessors | Total float | Free float | Resources | Cost | Wajid | RPI_P2 - BOQ ITEMS | RPI_P2 - CONSTRUCTION | RPI_P2 - PHASE | RPI_P2 - ZONES | RPI_P2 - DISCIPLINE / WORK TYPE | RPI_P2 - UTILITY NETWORK |
| --- | --- | --- | --- | --- | --- | --- | --- | --- | --- | --- | --- | --- | --- | --- | --- | --- | --- |
|  | 2 | **Manholes and Duct Banks** |  | 2017-08-17 | 2017-09-27 |  |  |  |  |  |  |  |  |  |  |  |  |
| CON-Z1-UTIL-COM-230 |  | Remaining Works for Construction of Communication Manholes and Duct Banks | 30d | 2017-08-17 | 2017-09-27 | CON-Z1-UTIL-COM-170 | 13.6d | 0d | Steel Fixer [1170 h]; Shuttering Carpenter [2340 h]; Concrete Mason [1950 h]; Common Labor / Helper [2340 h] | 65,616.23 | OK | 1.3.2.10 | CONS | CONS | ZONE-1&2 | COMM | COMM |
|  | 3 | **Instalaltion of Foundations for Pole of CCTV Camera** |  | 2017-08-17 | 2017-10-01 |  |  |  |  |  |  |  |  |  |  |  |  |
| CON-Z1-UTIL-COM-240 |  | Excavation of Foundations for Pole of CCTV Camera | 8d | 2017-08-17 | 2017-08-27 | CON-Z1-UTIL-COM-230 SS, CON-Z1-UTIL-COM-170 SS+2.4d | 13.6d | 0d | Operator - JCB [104 h]; JCB [112 h] | 26,246.49 | OK | 1.3.2.10 | CONS | CONS | ZONE-1&2 | COMM | COMM |
| CON-Z1-UTIL-COM-250 |  | Compaction and Lean Concrete | 8d | 2017-08-20 | 2017-08-29 | CON-Z1-UTIL-COM-240 SS+2.4d | 13.6d | 0d | Concrete Mason [624 h]; Common Labor / Helper [520 h] | 13,123.25 | OK | 1.3.2.10 | CONS | CONS | ZONE-1&2 | COMM | COMM |
| CON-Z1-UTIL-COM-260 |  | Concrete Work for Foundations With Anchor Bolts | 16d | 2017-08-23 | 2017-09-14 | CON-Z1-UTIL-COM-250 SS+2.4d | 13.6d | 0d | Steel Fixer [624 h]; Shuttering Carpenter [832 h]; Concrete Mason [1248 h]; Common Labor / Helper [1040 h] | 52,492.99 | OK | 1.3.2.10 | CONS | CONS | ZONE-1&2 | COMM | COMM |
| CON-Z1-UTIL-COM-270 |  | Installation of Poles for CCTV Camera | 26d | 2017-08-26 | 2017-10-01 | CON-Z1-UTIL-COM-260 SS+2.4d | 13.6d | 0d | Common Labor / Helper [2028 h]; Specialist Works Crew [676 h] | 39,369.74 | OK | 1.3.2.10 | CONS | CONS | ZONE-1&2 | COMM | COMM |
|  | 4 | **Installation of Field Equipment Cabinet (FEC) and CCTV Camera** |  | 2017-08-28 | 2017-09-18 |  |  |  |  |  |  |  |  |  |  |  |  |
| CON-Z1-UTIL-COM-280 |  | Instalaltion of CCTV Fied Equipment Cabinet (FEC) (18 No.) | 12d | 2017-08-28 | 2017-09-16 | CON-Z1-UTIL-COM-270 SS+2d | 13.6d | 0d | Specialist Works Crew [468 h]; LC Crew [312 h] | 39,369.74 | OK | 1.3.2.10 | CONS | CONS | ZONE-1&2 | COMM | COMM |
| CON-Z1-UTIL-COM-290 |  | Installation of Fixed Camera (27 No.) | 12d | 2017-08-30 | 2017-09-18 | CON-Z1-UTIL-COM-280 SS+2d | 13.6d | 0d | LC Crew [208 h] | 118,109.22 | OK | 1.3.2.10 | CONS | CONS | ZONE-1&2 | COMM | COMM |
| CON-Z1-UTIL-COM-300 |  | Installation of PTZ Camera (4 No.) | 6d | 2017-08-30 | 2017-09-11 | CON-Z1-UTIL-COM-290 SS | 13.6d | 0d | LC Crew [208 h] | 39,369.74 | OK | 1.3.2.10 | CONS | CONS | ZONE-1&2 | COMM | COMM |
|  | 5 | **Internal Cabling System for CCTV** |  | 2017-09-06 | 2017-10-28 |  |  |  |  |  |  |  |  |  |  |  |  |
| CON-Z1-UTIL-COM-310 |  | Installation and Termination of Coaxial Cables from FEC to Camera | 8d | 2017-09-06 | 2017-09-16 | CON-Z1-UTIL-COM-300 SS+2d | 13.6d | 0d | LC Crew [208 h] | 32,808.12 | OK | 1.3.2.10 | CONS | CONS | ZONE-1&2 | COMM | COMM |
| CON-Z1-UTIL-COM-320 |  | Instalaltion and Termination of Copper Control Cables for PTZ Camera | 8d | 2017-09-09 | 2017-09-18 | CON-Z1-UTIL-COM-310 SS+2d | 13.6d | 0d | LC Crew [208 h] | 32,808.12 | OK | 1.3.2.10 | CONS | CONS | ZONE-1&2 | COMM | COMM |
| CON-Z1-UTIL-COM-330 |  | FOC Splicing (24 Strand) | 4d | 2017-09-11 | 2017-09-16 | CON-Z1-UTIL-COM-320 SS+2d | 13.6d | 0d | LC Crew [208 h] | 13,123.25 | OK | 1.3.2.10 | CONS | CONS | ZONE-1&2 | COMM | COMM |
| CON-Z1-UTIL-COM-340 |  | FOC Splicing (32 Strand) | 4d | 2017-09-16 | 2017-09-20 | CON-Z1-UTIL-COM-330 | 13.6d | 0d | LC Crew [208 h] | 13,123.25 | OK | 1.3.2.10 | CONS | CONS | ZONE-1&2 | COMM | COMM |
| CON-Z1-UTIL-COM-350 |  | FOC Splicing (48 Strand) | 4d | 2017-09-20 | 2017-09-26 | CON-Z1-UTIL-COM-340 | 13.6d | 8.8d | LC Crew [208 h] | 13,123.25 | OK | 1.3.2.10 | CONS | CONS | ZONE-1&2 | COMM | COMM |
| CON-Z1-UTIL-COM-360 |  | Testing & Precommissioning of Communication and Security Systrems of Zone 1 & Zone 2 | 18d | 2017-10-07 | 2017-10-28 | CON-Z1-UTIL-COM-0040, CON-Z1-UTIL-COM-350, CON-Z1-UTIL-COM-370 SS+2d | 4.8d | 4.4d | LC Crew [208 h] | 26,246.49 | OK | 1.3.2.10 | CONS | CONS | ZONE-1&2 | COMM | COMM |
|  | 3 | **CONSTRUCTION FOR ZONE - 3** |  | 2016-08-09 | 2017-11-01 |  |  |  |  |  |  |  |  |  |  |  |  |
|  | 1 | **UTILITIES & SERVICES WORKS** |  | 2016-08-09 | 2017-11-01 |  |  |  |  |  |  |  |  |  |  |  |  |
|  | 1 | **Site Preparation, demolition and earth works** |  | 2016-08-09 | 2017-05-31 |  |  |  |  |  |  |  |  |  |  |  |  |
|  | 1 | **Site Preparation (General)** |  | 2016-08-09 | 2016-10-06 |  |  |  |  |  |  |  |  |  |  |  |  |
| GE-SIT-PREP-GE-0010 |  | Accessebility of Site | 30d | 2016-08-09 | 2016-09-18 | GE-W-SEC-GE-GE-0010 SS, GE-ML-GE-GE-GE-0000 | 26.8d | 0d | Loader [420 h]; Common Labor / Helper [3900 h]; Dump Truck [420 h] | 397,089.15 | OK |  |  | GEN |  |  |  |
| GE-SIT-PREP-GE-0020 |  | Preparation of Temporary Site Access Roads | 30d | 2016-08-21 | 2016-09-29 | GE-SIT-PREP-GE-0010 SS+10d | 26.8d | 0d | Common Labor / Helper [5850 h]; Loader [420 h]; Excavator [420 h] | 397,089.15 | OK |  |  | GEN |  |  |  |
| GE-SIT-PREP-GE-0030 |  | Safety Arrangement and General Site Cleaning | 30d | 2016-08-28 | 2016-10-06 | GE-SIT-PREP-GE-0020 SS+6d, GE-SIT-PREP-GE-0010 SS | 26.8d | 0d | Common Labor / Helper [3900 h] | 340,362.13 | OK |  |  | GEN |  |  |  |

Notes:
- CON-Z1-UTIL-COM-230: Expenses: (New Expense Item) 65616.2
- CON-Z1-UTIL-COM-240: Expenses: (New Expense Item) 26246.5
- CON-Z1-UTIL-COM-250: Expenses: (New Expense Item) 13123.2
- CON-Z1-UTIL-COM-260: Expenses: (New Expense Item) 52493
- CON-Z1-UTIL-COM-270: Expenses: (New Expense Item) 39369.7
- CON-Z1-UTIL-COM-280: Expenses: (New Expense Item) 39369.7
- CON-Z1-UTIL-COM-290: Expenses: (New Expense Item) 118109
- CON-Z1-UTIL-COM-300: Expenses: (New Expense Item) 39369.7
- CON-Z1-UTIL-COM-310: Expenses: (New Expense Item) 32808.1
- CON-Z1-UTIL-COM-320: Expenses: (New Expense Item) 32808.1
- CON-Z1-UTIL-COM-330: Expenses: (New Expense Item) 13123.2
- CON-Z1-UTIL-COM-340: Expenses: (New Expense Item) 13123.2
- CON-Z1-UTIL-COM-350: Expenses: (New Expense Item) 13123.2
- CON-Z1-UTIL-COM-360: Expenses: (New Expense Item) 26246.5
- GE-SIT-PREP-GE-0010: Expenses: (New Expense Item) 397089
- GE-SIT-PREP-GE-0020: Expenses: (New Expense Item) 397089
- GE-SIT-PREP-GE-0030: Expenses: (New Expense Item) 340362

| ID | WBS | Activity | Duration | Start | Finish | Predecessors | Total float | Free float | Resources | Cost | Wajid | RPI_P2 - PHASE |
| --- | --- | --- | --- | --- | --- | --- | --- | --- | --- | --- | --- | --- |
|  | 2 | **Relocation of Storage along with Block-6 Material and Preparation of Area for Handing Over** |  | 2016-08-20 | 2016-09-22 |  |  |  |  |  |  |  |
|  | 1 | **Preparation of Storage Area for Shifting Block 6 Materils** |  | 2016-08-20 | 2016-08-23 |  |  |  |  |  |  |  |
| GE-UTIL-STOR-GE-0010 |  | Preparation of Temporary Storage area for Shifting Block -6 Materials | 3.2d | 2016-08-20 | 2016-08-23 | GE-W-SEC-GE-GE-0010, GE-ML-GE-GE-GE-0000 FS+10d, GE-CL-DL-GE-GE-0060, GE-CL-DL-GE-GE-0070 | 21.6d | 0d | Common Labor / Helper [624 h]; Excavator [44.8 h]; Dump Truck [44.8 h]; Shuttering Carpenter [416 h] | 132,363.05 | OK | GEN |
|  | 2 | **Shifting of Civil and Architectural Work Materials** |  | 2016-08-20 | 2016-08-25 |  |  |  |  |  |  |  |
| GE-UTIL-REL-GE-0010 |  | Shifting of Civil Work Materials | 5d | 2016-08-20 | 2016-08-25 | GE-UTIL-STOR-GE-0010 SS+0.8d | 41.2d | 0d | Mobile Crane ( 25-60 Ton) [70 h]; Common Labor / Helper [65 h]; Flat Bed Trailer [70 h]; Driver - Flat Bed Trailer [65 h]; Operator - Mobile Crane [65 h] | 264,726.1 | OK | GEN |
| GE-UTIL-REL-GE-0020 |  | Shifting of Architecrual Materials (Tiles,Doors and Frames and Plumbing Fixures) | 4.8d | 2016-08-20 | 2016-08-25 | GE-UTIL-REL-GE-0010 SS | 41.2d | 19.6d | Common Labor / Helper [936 h]; Mobile Crane ( 25-60 Ton) [67.2 h]; Flat Bed Trailer [67.2 h]; Operator - Mobile Crane [62.4 h]; Driver - Flat Bed Trailer [62.4 h] | 264,726.1 | OK | GEN |
|  | 3 | **Shifting of Electrical Work Materials** |  | 2016-08-20 | 2016-08-29 |  |  |  |  |  |  |  |
| GE-UTIL-REL-GE-0030 |  | Shifting of MV & LV Cables,Transformers,Circuit Breaker and ATS | 8d | 2016-08-20 | 2016-08-29 | GE-UTIL-STOR-GE-0010 SS+0.8d | 38d | 0d | Common Labor / Helper [1040 h]; Mobile Crane ( 25-60 Ton) [112 h]; Flat Bed Trailer [112 h]; Driver - Flat Bed Trailer [104 h]; Operator - Mobile Crane [104 h] | 63,534.26 | OK | GEN |
| GE-UTIL-REL-GE-0040 |  | Shifting of Distribution Panel Boards | 8d | 2016-08-20 | 2016-08-29 | GE-UTIL-REL-GE-0030 SS | 38d | 0d |  | 47,650.7 | OK | GEN |
| GE-UTIL-REL-GE-0050 |  | Shifting of SL Poles and Street Lighting Fixures | 8d | 2016-08-20 | 2016-08-29 | GE-UTIL-REL-GE-0040 SS | 38d | 0d |  | 47,650.7 | OK | GEN |
| GE-UTIL-REL-GE-0060 |  | Shifitng of Solar Lighting and Power Panel | 8d | 2016-08-20 | 2016-08-29 | GE-UTIL-REL-GE-0050 SS | 38d | 0d |  | 47,650.7 | OK | GEN |
| GE-UTIL-REL-GE-0070 |  | Shfiting of Disconnect Switches | 8d | 2016-08-20 | 2016-08-29 | GE-UTIL-REL-GE-0060 SS | 38d | 0d |  | 47,650.7 | OK | GEN |
| GE-UTIL-REL-GE-0080 |  | Shifting of Building Wires and Junction Boxes | 8d | 2016-08-20 | 2016-08-29 | GE-UTIL-REL-GE-0070 SS | 38d | 0d |  | 47,650.7 | OK | GEN |
| GE-UTIL-REL-GE-0090 |  | Shifting of Splicing and Termination Kits and Cable Lugs | 8d | 2016-08-20 | 2016-08-29 | GE-UTIL-REL-GE-0080 SS | 38d | 0d |  | 47,650.7 | OK | GEN |
| GE-UTIL-REL-GE-0100 |  | Shifitng of Electrical Materials for Grounding System,Wiring Devices and Miscellaneous Elect items | 8d | 2016-08-20 | 2016-08-29 | GE-UTIL-REL-GE-0090 SS | 38d | 16.4d |  | 47,650.7 | OK | GEN |
|  | 5 | **Shifting of Mechanical Work Materials** |  | 2016-08-20 | 2016-08-25 |  |  |  |  |  |  |  |
| GE-UTIL-REL-GE-0110 |  | Shifting of Submersible Pumps | 4.8d | 2016-08-20 | 2016-08-25 | GE-UTIL-STOR-GE-0010 SS+0.8d | 41.2d | 0d | Common Labor / Helper [624 h]; Mobile Crane ( 25-60 Ton) [67.2 h]; Flat Bed Trailer [67.2 h]; Driver - Dump Truck [62.4 h]; Operator - Mobile Crane [62.4 h] | 79,417.83 | OK | GEN |
| GE-UTIL-REL-GE-0120 |  | Shifting of Diesel Generators | 4.8d | 2016-08-20 | 2016-08-25 | GE-UTIL-REL-GE-0110 SS | 41.2d | 0d |  | 79,417.83 | OK | GEN |
| GE-UTIL-REL-GE-0130 |  | Shifting of Fire Hydrants | 4.8d | 2016-08-20 | 2016-08-25 | GE-UTIL-REL-GE-0120 SS | 41.2d | 0d |  | 79,417.83 | OK | GEN |
| GE-UTIL-REL-GE-0140 |  | Shifting of Exhaust Fans | 4.8d | 2016-08-20 | 2016-08-25 | GE-UTIL-REL-GE-0130 SS | 41.2d | 0d |  | 79,417.83 | OK | GEN |
| GE-UTIL-REL-GE-0150 |  | Shfiting of Flouropolymer Coated Stud Bolts | 4.8d | 2016-08-20 | 2016-08-25 | GE-UTIL-REL-GE-0140 SS | 41.2d | 19.6d |  | 79,417.83 | OK | GEN |
|  | 4 | **Shifting of Communication Work Materials** |  | 2016-08-20 | 2016-08-23 |  |  |  |  |  |  |  |
| GE-UTIL-REL-GE-0160 |  | Shifting of Fiber Optic Cables,Patch Panels and Fiber Optic Splice Closure | 2.4d | 2016-08-20 | 2016-08-23 | GE-UTIL-STOR-GE-0010 SS+0.8d | 21.6d | 0d | Common Labor / Helper [156 h]; Mobile Crane ( 25-60 Ton) [33.6 h]; Flat Bed Trailer [33.6 h]; Operator - Mobile Crane [31.2 h]; Driver - Flat Bed Trailer [31.2 h] | 52,945.22 | OK | GEN |
| GE-UTIL-REL-GE-0170 |  | Shifting of Copper Cables,Ducts and Sub Ducts Conduits and Fittings,Copper Cable Closure and Copper Cables | 2.4d | 2016-08-20 | 2016-08-23 | GE-UTIL-REL-GE-0160 SS | 21.6d | 0d |  | 52,945.22 | OK | GEN |
| GE-UTIL-REL-GE-0180 |  | Shifting of Telecom Equipments,CCTV system Materials and Security Access System | 2.4d | 2016-08-20 | 2016-08-23 | GE-UTIL-REL-GE-0170 SS | 21.6d | 0d |  | 52,945.22 | OK | GEN |
| GE-UTIL-REL-GE-0190 |  | Shifting of IP Phone System,Comm OSP System and ISP Data System | 2.4d | 2016-08-20 | 2016-08-23 | GE-UTIL-REL-GE-0180 SS | 21.6d | 0d |  | 52,945.22 | OK | GEN |
| GE-UTIL-REL-GE-0200 |  | Shifting of Comm Building H/W Materials and Fire Alarm System | 2.4d | 2016-08-20 | 2016-08-23 | GE-UTIL-REL-GE-0190 SS | 21.6d | 0d |  | 52,945.22 | OK | GEN |

Notes:
- GE-UTIL-STOR-GE-0010: Expenses: (New Expense Item) 132363
- GE-UTIL-REL-GE-0010: Expenses: (New Expense Item) 264726
- GE-UTIL-REL-GE-0020: Expenses: (New Expense Item) 264726
- GE-UTIL-REL-GE-0030: Expenses: (New Expense Item) 63534.3
- GE-UTIL-REL-GE-0040: Expenses: (New Expense Item) 47650.7
- GE-UTIL-REL-GE-0050: Expenses: (New Expense Item) 47650.7
- GE-UTIL-REL-GE-0060: Expenses: (New Expense Item) 47650.7
- GE-UTIL-REL-GE-0070: Expenses: (New Expense Item) 47650.7
- GE-UTIL-REL-GE-0080: Expenses: (New Expense Item) 47650.7
- GE-UTIL-REL-GE-0090: Expenses: (New Expense Item) 47650.7
- GE-UTIL-REL-GE-0100: Expenses: (New Expense Item) 47650.7
- GE-UTIL-REL-GE-0110: Expenses: (New Expense Item) 79417.8
- GE-UTIL-REL-GE-0120: Expenses: (New Expense Item) 79417.8
- GE-UTIL-REL-GE-0130: Expenses: (New Expense Item) 79417.8
- GE-UTIL-REL-GE-0140: Expenses: (New Expense Item) 79417.8
- GE-UTIL-REL-GE-0150: Expenses: (New Expense Item) 79417.8
- GE-UTIL-REL-GE-0160: Expenses: (New Expense Item) 52945.2
- GE-UTIL-REL-GE-0170: Expenses: (New Expense Item) 52945.2
- GE-UTIL-REL-GE-0180: Expenses: (New Expense Item) 52945.2
- GE-UTIL-REL-GE-0190: Expenses: (New Expense Item) 52945.2
- GE-UTIL-REL-GE-0200: Expenses: (New Expense Item) 52945.2

| ID | WBS | Activity | Duration | Start | Finish | Predecessors | Total float | Free float | Resources | Cost | Wajid | RPI_P2 - PHASE | RPI_P2 - BOQ ITEMS | RPI_P2 - CONSTRUCTION | RPI_P2 - ZONES | RPI_P2 - DISCIPLINE / WORK TYPE | RPI_P2 - UTILITY NETWORK |
| --- | --- | --- | --- | --- | --- | --- | --- | --- | --- | --- | --- | --- | --- | --- | --- | --- | --- |
|  | 6 | **Shifting of Plumbing and External Work Materials** |  | 2016-08-23 | 2016-09-01 |  |  |  |  |  |  |  |  |  |  |  |  |
| GE-UTIL-REL-GE-0210 |  | Shifting of Pipes and Fittings | 8d | 2016-08-23 | 2016-09-01 | GE-UTIL-REL-GE-0200 | 21.6d | 0d | Common Labor / Helper [520 h]; Mobile Crane ( 25-60 Ton) [112 h]; Flat Bed Trailer [112 h]; Driver - Flat Bed Trailer [104 h]; Operator - Mobile Crane [104 h] | 66,181.53 | OK | GEN |  |  |  |  |  |
| GE-UTIL-REL-GE-0220 |  | Shifting of Playground Equipments and Fitness equipments | 8d | 2016-08-23 | 2016-09-01 | GE-UTIL-REL-GE-0210 SS | 21.6d | 0d |  | 66,181.53 | OK | GEN |  |  |  |  |  |
| GE-UTIL-REL-GE-0230 |  | Shifting of Harscape Materials | 8d | 2016-08-23 | 2016-09-01 | GE-UTIL-REL-GE-0220 SS | 21.6d | 0d |  | 66,181.53 | OK | GEN |  |  |  |  |  |
| GE-UTIL-REL-GE-0240 |  | Shifting of Irrigation Equipments | 8d | 2016-08-23 | 2016-09-01 | GE-UTIL-REL-GE-0230 SS | 21.6d | 0d |  | 66,181.53 | OK | GEN |  |  |  |  |  |
|  | 7 | **Shifting of Hangers and Temporary Fence** |  | 2016-08-25 | 2016-09-10 |  |  |  |  |  |  |  |  |  |  |  |  |
| GE-UTIL-REL-GE-0250 |  | Shifting of Hangers and Temporary Fence | 13d | 2016-08-25 | 2016-09-10 | GE-UTIL-REL-GE-0240 SS+2.4d | 21.6d | 0d | Mobile Crane ( 25-60 Ton) [182 h]; Flat Bed Trailer [182 h]; Common Labor / Helper [845 h]; Driver - Flat Bed Trailer [169 h]; Operator - Mobile Crane [169 h] | 397,089.15 | OK | GEN |  |  |  |  |  |
|  | 8 | **Demolishing and Cleaning of Block-6 Storage Area** |  | 2016-08-28 | 2016-09-22 |  |  |  |  |  |  |  |  |  |  |  |  |
| GE-UTIL-REL-GE-0260 |  | Demolishing of Block-6 Storage Area | 5.6d | 2016-08-28 | 2016-09-03 | GE-UTIL-REL-GE-0250 SS+1.6d | 21.6d | 0d | Common Labor / Helper [364 h]; Shuttering Carpenter [364 h]; Scaffolder [218.4 h]; Excavator [78.4 h]; Operator - Excavator [72.8 h]; Dump Truck [78.4 h]; Driver - Dump Truck [72.8 h] | 132,363.05 | OK | GEN |  |  |  |  |  |
| GE-UTIL-REL-GE-0270 |  | Cleaning of Block-6 Storage Area | 10d | 2016-09-06 | 2016-09-22 | GE-UTIL-REL-GE-0260 FS+2.4d | 21.6d | 0d | Common Labor / Helper [200 h] | 132,363.05 | OK | GEN |  |  |  |  |  |
|  | 3 | **Site Leveling, Grading, demolition and Earth Works** |  | 2016-08-21 | 2017-05-31 |  |  |  |  |  |  |  |  |  |  |  |  |
| CON-Z3-UTIL-SIT-0010 |  | Site Preparation (Demolition and Removal of Unsuitable Materials) | 37d | 2016-08-21 | 2016-10-08 | GE-ML-GE-GE-GE-0000, CON-CON-CON-CON-0010 FS+10d, GE-CL-DL-GE-GE-0080 | 41.8d | 0d | Common Labor / Helper [7215 h]; Operator - Excavator [962 h]; Driver - Dump Truck [962 h]; Operator - Grader [481 h]; Operator - JCB [481 h]; Excavator [1036 h]; Loader [1036 h]; Dump Truck [1036 h]; Grader [518 h]; JCB [518 h] | 378,180.14 | OK | CONS | 1.3.3.10 | CONS | ZONE-3 |  |  |
| CON-Z3-UTIL-SIT-0020 |  | Earth Works (Cut & Fill - Leveling & Grading of un-even areas in general at Zone-3) | 52d | 2017-04-01 | 2017-05-31 | CON-Z3-UTIL-SIT-0010 FS+150d | 123.8d | 123.6d | Grader [728 h]; Operator - Grader [520 h]; Operator - JCB [520 h]; Operator - Excavator [520 h]; Driver - Dump Truck [520 h]; Dump Truck [2184 h]; JCB [728 h]; Excavator [2184 h] | 3,403,621.28 | OK | CONS | 1.3.3.10 | CONS | ZONE-3 |  |  |
|  | 2 | **Potable and Fire Water System** |  | 2016-09-28 | 2017-06-04 |  |  |  |  |  |  |  |  |  |  |  |  |
|  | 1 | **Potable and Fire Water Lines** |  | 2016-09-28 | 2017-05-31 |  |  |  |  |  |  |  |  |  |  |  |  |
|  | 1 | **Potable Water Line - RTR 250mm dia at Road A = 640 Lm** |  | 2016-09-28 | 2016-11-05 |  |  |  |  |  |  |  |  |  |  |  |  |
| CON-Z3-UT-PW-PL-0050 |  | Installation of Thurst Blocks of already installed Pipe line | 12d | 2016-09-28 | 2016-10-12 | CON-CON-CON-CON-0010 FS+39d | 30.8d | 0d | Steel Fixer [240 h]; Shuttering Carpenter [240 h]; Concrete Mason [240 h]; Common Labor / Helper [120 h]; Driver - Conc. Transit Mixers [156 h]; Operator - Concrete Pump [156 h]; Concrete Transit Mixers [168 h]; Concrete Pump [168 h] | 43,007.32 |  | CONS | 1.3.3.20 | CONS | ZONE-3 | MECH | PW |
| CON-Z3-UT-PW-PL-0060 |  | Testing and Precommissioning | 20d | 2016-10-12 | 2016-11-05 | GE-MS-ENG-ENG-0020, CON-Z3-UT-PW-PL-0050, GE-MS-ENG-ENG-0050 | 30.8d | 0d | Plumber [2000 h]; Common Labor / Helper [2000 h]; RTR Pipe Crew [520 h]; Driver - Water Tanker [800 h]; Water Tanker [800 h] | 172,029.28 |  | CONS | 1.3.3.20 | CONS | ZONE-3 | MECH | PW |
|  | 6 | **Potable Water Line - RTR 250mm dia at Road B = 597 Lm** |  | 2016-10-12 | 2016-11-22 |  |  |  |  |  |  |  |  |  |  |  |  |
| CON-Z3-UT-PW-PL-0120 |  | Installation of Thurst Blocks of already installed Pipe line | 15d | 2016-10-12 | 2016-10-30 | CON-Z3-UT-PW-PL-0050 | 36.8d | 0d | Steel Fixer [975 h]; Shuttering Carpenter [975 h]; Concrete Mason [975 h]; Common Labor / Helper [1950 h]; Driver - Conc. Transit Mixers [195 h]; Operator - Concrete Pump [195 h]; Concrete Transit Mixers [210 h]; Concrete Pump [210 h] | 43,007.32 |  | CONS | 1.3.3.20 | CONS | ZONE-3 | MECH | PW |
| CON-Z3-UT-PW-PL-0125 |  | Testing and Precommissioning | 20d | 2016-10-30 | 2016-11-22 | GE-MS-ENG-ENG-0050, CON-Z3-UT-PW-PL-0120, CON-Z3-UT-PW-PL-0060 SS | 62.8d | 20d | Plumber [260 h]; Common Labor / Helper [208 h]; RTR Pipe Crew [104 h]; Driver - Water Tanker [52 h]; Water Tanker [56 h] | 172,029.28 |  | CONS | 1.3.3.20 | CONS | ZONE-3 | MECH | PW |
|  | 16 | **Potable Water Line - RTR 200mm dia at Road 2 = 1180 Lm** |  | 2016-10-30 | 2016-12-27 |  |  |  |  |  |  |  |  |  |  |  |  |
| CON-Z3-UT-PW-PL-760 |  | Installation of Thurst Blocks of already installed Pipe line | 20d | 2016-10-30 | 2016-11-22 | CON-Z3-UT-PW-PL-0120 | 42.8d | 0d | Steel Fixer [208 h]; Shuttering Carpenter [208 h]; Concrete Mason [208 h]; Common Labor / Helper [208 h]; Driver - Conc. Transit Mixers [52 h]; Operator - Concrete Pump [52 h]; Concrete Transit Mixers [56 h]; Concrete Pump [56 h] | 86,014.64 |  | CONS | 1.3.3.20 | CONS | ZONE-3 | MECH | PW |
| CON-Z3-UT-PW-PL-770 |  | Testing and Precommissioning | 30d | 2016-11-22 | 2016-12-27 | CON-Z3-UT-PW-PL-0125 SS, GE-MS-ENG-ENG-0050, CON-Z3-UT-PW-PL-760 | 42.8d | 6d | Plumber [1950 h]; Common Labor / Helper [150 h]; RTR Pipe Crew [780 h]; Driver - Water Tanker [150 h]; Water Tanker [150 h] | 344,058.56 |  | CONS | 1.3.3.20 | CONS | ZONE-3 | MECH | PW |

Notes:
- GE-UTIL-REL-GE-0210: Expenses: (New Expense Item) 66181.5
- GE-UTIL-REL-GE-0220: Expenses: (New Expense Item) 66181.5
- GE-UTIL-REL-GE-0230: Expenses: (New Expense Item) 66181.5
- GE-UTIL-REL-GE-0240: Expenses: (New Expense Item) 66181.5
- GE-UTIL-REL-GE-0250: Expenses: (New Expense Item) 397089
- GE-UTIL-REL-GE-0260: Expenses: (New Expense Item) 132363
- GE-UTIL-REL-GE-0270: Expenses: (New Expense Item) 132363
- CON-Z3-UTIL-SIT-0010: Expenses: (New Expense Item) 378180
- CON-Z3-UTIL-SIT-0020: Expenses: (New Expense Item) 3403621
- CON-Z3-UT-PW-PL-0050: Expenses: (New Expense Item) 43007.3
- CON-Z3-UT-PW-PL-0060: Expenses: (New Expense Item) 172029
- CON-Z3-UT-PW-PL-0120: Expenses: (New Expense Item) 43007.3
- CON-Z3-UT-PW-PL-0125: Expenses: (New Expense Item) 172029
- CON-Z3-UT-PW-PL-760: Expenses: (New Expense Item) 86014.6
- CON-Z3-UT-PW-PL-770: Expenses: (New Expense Item) 344059

| ID | WBS | Activity | Duration | Start | Finish | Predecessors | Total float | Free float | Resources | Cost | RPI_P2 - BOQ ITEMS | RPI_P2 - CONSTRUCTION | RPI_P2 - PHASE | RPI_P2 - ZONES | RPI_P2 - DISCIPLINE / WORK TYPE | RPI_P2 - UTILITY NETWORK |
| --- | --- | --- | --- | --- | --- | --- | --- | --- | --- | --- | --- | --- | --- | --- | --- | --- |
|  | 7 | **Potable Water Line - RTR 250mm dia at Road 3 = 1604 Lm** |  | 2016-10-31 | 2017-01-03 |  |  |  |  |  |  |  |  |  |  |  |
| CON-Z3-UT-PW-PL-0260 |  | Installation of Thurst Blocks of already installed Pipe line | 25d | 2016-10-31 | 2016-11-29 | CON-Z3-UT-PW-PL-0120 FS+1d | 36.8d | 0d | Steel Fixer [125 h]; Shuttering Carpenter [125 h]; Concrete Mason [125 h]; Common Labor / Helper [125 h]; Driver - Conc. Transit Mixers [325 h]; Operator - Concrete Pump [325 h]; Concrete Transit Mixers [350 h]; Concrete Pump [350 h] | 86,014.64 | 1.3.3.20 | CONS | CONS | ZONE-3 | MECH | PW |
| CON-Z3-UT-PW-PL-0270 |  | Testing and Precommissioning | 30d | 2016-11-29 | 2017-01-03 | CON-Z3-UT-PW-PL-0260, CON-Z3-UT-PW-PL-770 SS | 36.8d | 2d | Plumber [260 h]; Common Labor / Helper [208 h]; RTR Pipe Crew [104 h]; Driver - Water Tanker [52 h]; Water Tanker [56 h] | 344,058.56 | 1.3.3.20 | CONS | CONS | ZONE-3 | MECH | PW |
|  | 8 | **Potable Water Line - RTR 300mm dia at Road 3 = 620 Lm** |  | 2016-11-29 | 2016-12-28 |  |  |  |  |  |  |  |  |  |  |  |
| CON-Z3-UT-PW-PL-800 |  | Installation of Thurst Blocks of already installed Pipe line | 10d | 2016-11-29 | 2016-12-11 | CON-Z3-UT-PW-PL-0260 | 89.4d | 0d |  | 25,804.39 | 1.3.3.20 | CONS | CONS | ZONE-3 | MECH | PW |
| CON-Z3-UT-PW-PL-810 |  | Testing and Precommissioning | 15d | 2016-12-11 | 2016-12-28 | CON-Z3-UT-PW-PL-800, CON-Z3-UT-PW-PL-0270 SS | 111.4d | 10d | Common Labor / Helper [780 h]; Plumber [975 h]; RTR Pipe Crew [390 h]; Water Tanker [210 h] | 103,217.57 | 1.3.3.20 | CONS | CONS | ZONE-3 | MECH | PW |
|  | 17 | **Potable Water Line - RTR 350mm dia at Road 3 = 580 Lm** |  | 2016-12-11 | 2017-01-09 |  |  |  |  |  |  |  |  |  |  |  |
| CON-Z3-UT-PW-PL-820 |  | Installation of Thurst Blocks of already installed Pipe line | 10d | 2016-12-11 | 2016-12-22 | CON-Z3-UT-PW-PL-800 | 89.4d | 0d | Steel Fixer [520 h]; Shuttering Carpenter [520 h]; Common Labor / Helper [780 h]; Concrete Mason [520 h] | 25,804.39 | 1.3.3.20 | CONS | CONS | ZONE-3 | MECH | PW |
| CON-Z3-UT-PW-PL-830 |  | Testing and Precommissioning | 15d | 2016-12-22 | 2017-01-09 | CON-Z3-UT-PW-PL-810 SS, CON-Z3-UT-PW-PL-820 | 101.4d | 12d |  | 103,217.57 | 1.3.3.20 | CONS | CONS | ZONE-3 | MECH | PW |
|  | 18 | **Potable Water Line - RTR 250mm dia at Road A = 700 Lm** |  | 2016-12-22 | 2017-01-26 |  |  |  |  |  |  |  |  |  |  |  |
| CON-Z3-UT-PW-PL-840 |  | Installation of Thurst Blocks of already installed Pipe line | 12d | 2016-12-22 | 2017-01-05 | CON-Z3-UT-PW-PL-820 | 89.4d | 0d |  | 34,405.86 | 1.3.3.20 | CONS | CONS | ZONE-3 | MECH | PW |
| CON-Z3-UT-PW-PL-850 |  | Testing and Precommissioning | 18d | 2017-01-05 | 2017-01-26 | CON-Z3-UT-PW-PL-840, CON-Z3-UT-PW-PL-830 SS | 89.4d | 3.6d | Plumber [468 h]; Common Labor / Helper [468 h]; Water Tanker [50.4 h]; Driver - Water Tanker [46.8 h]; RTR Pipe Crew [468 h] | 137,623.42 | 1.3.3.20 | CONS | CONS | ZONE-3 | MECH | PW |
|  | 4 | **Potable Water Line - RTR 200mm dia at Road A = 35 Lm** |  | 2016-12-20 | 2017-01-14 |  |  |  |  |  |  |  |  |  |  |  |
| CON-Z3-UT-PW-PL-0070 |  | Excavation of Trench | 0.8d | 2016-12-20 | 2016-12-20 | CON-Z3-UT-PW-PL-0060 FS+39d | 30.8d | 0d | Common Labor / Helper [39 h]; Operator - Excavator [13 h]; Driver - Dump Truck [13 h]; Operator - JCB [13 h]; Excavator [14 h]; Dump Truck [14 h]; JCB [14 h] | 12,902.2 | 1.3.3.20 | CONS | CONS | ZONE-3 | MECH | PW |
| CON-Z3-UT-PW-PL-0080 |  | Compaction and Sand bedding | 0.8d | 2016-12-24 | 2016-12-25 | CON-Z3-UT-PW-PL-0070 SS+3.2d | 85.8d | 0d | Common Labor / Helper [52 h]; Operator - Loader [13 h]; Driver - Dump Truck [13 h]; Operator - Bobcat [13 h]; Operator - JCB [13 h]; Loader [14 h]; Dump Truck [14 h]; Bobcat [14 h]; Roller-Compactor (2~10 Ton) [14 h]; Plate Compactor [14 h]; Water Tanker [14 h]; JCB [14 h] | 8,601.46 | 1.3.3.20 | CONS | CONS | ZONE-3 | MECH | PW |
| CON-Z3-UT-PW-PL-0090 |  | Pipe Laying | 0.8d | 2016-12-26 | 2016-12-27 | PR-Z3-UT-PW-121-0080, CON-Z3-UT-PW-PL-0080 SS+2.4d | 85.8d | 0d | Plumber [65 h]; Common Labor / Helper [39 h]; RTR Pipe Crew [26 h]; Operator - Mobile Crane [13 h]; Driver - Flat Bed Trailer [13 h]; Mobile Crane ( 25-60 Ton) [14 h]; Flat Bed Trailer [14 h] | 25,804.39 | 1.3.3.20 | CONS | CONS | ZONE-3 | MECH | PW |
| CON-Z3-UT-PW-PL-0100 |  | Installation of Thurst Block | 4d | 2016-12-31 | 2017-01-04 | CON-Z3-UT-PW-PL-0090 SS+4d | 85.8d | 0d | Steel Fixer [208 h]; Shuttering Carpenter [208 h]; Concrete Mason [156 h]; Common Labor / Helper [208 h]; Driver - Conc. Transit Mixers [52 h]; Operator - Concrete Pump [52 h]; Concrete Transit Mixers [56 h]; Concrete Pump [56 h] | 8,601.46 | 1.3.3.20 | CONS | CONS | ZONE-3 | MECH | PW |
| CON-Z3-UT-PW-PL-0110 |  | Backfilling | 4d | 2017-01-04 | 2017-01-09 | CON-Z3-UT-PW-PL-0090, CON-Z3-UT-PW-PL-0100, PR-Z3-CW-CW-26-0080 | 85.8d | 0d | Common Labor / Helper [208 h]; Operator - Loader [52 h]; Driver - Dump Truck [52 h]; Operator - Bobcat [52 h]; Operator - Roller-Compactor (2~10 Ton) [52 h]; Driver - Water Tanker [52 h]; Operator - JCB [52 h]; Loader [56 h]; Dump Truck [56 h]; Bobcat [56 h]; Roller-Compactor (2~10 Ton) [56 h]; Plate Compactor [56 h]; Vibrators [56 h]; Water Tanker [56 h]; JCB [56 h] | 12,902.2 | 1.3.3.20 | CONS | CONS | ZONE-3 | MECH | PW |
| CON-Z3-UT-PW-PL-0130 |  | Testing and Precommissioning | 4d | 2017-01-09 | 2017-01-14 | CON-Z3-UT-PW-PL-0270, CON-Z3-UT-PW-PL-0110, CON-Z3-UT-PW-PL-850 SS | 85.8d | 0d | Plumber [260 h]; Common Labor / Helper [260 h]; RTR Pipe Crew [104 h]; Driver - Water Tanker [10.4 h]; Water Tanker [11.2 h] | 17,202.93 | 1.3.3.20 | CONS | CONS | ZONE-3 | MECH | PW |
|  | 5 | **Potable Water Line - RTR 200mm dia at Road B = 35 Lm** |  | 2016-12-21 | 2017-01-14 |  |  |  |  |  |  |  |  |  |  |  |
| CON-Z3-UT-PW-PL-0210 |  | Excavation of Trench | 0.8d | 2016-12-21 | 2016-12-21 | CON-Z3-UT-PW-PL-0070 | 30.8d | 0d | Common Labor / Helper [39 h]; Operator - Excavator [13 h]; Driver - Dump Truck [13 h]; Operator - JCB [13 h]; Excavator [14 h]; Dump Truck [14 h] | 12,902.2 | 1.3.3.20 | CONS | CONS | ZONE-3 | MECH | PW |
| CON-Z3-UT-PW-PL-0220 |  | Compaction and Sand bedding | 0.8d | 2016-12-25 | 2016-12-25 | CON-Z3-UT-PW-PL-0210 SS+3.2d | 89.8d | 0d | Common Labor / Helper [52 h]; Operator - Loader [13 h]; Driver - Dump Truck [13 h]; Operator - Bobcat [13 h]; Operator - JCB [13 h] | 8,601.46 | 1.3.3.20 | CONS | CONS | ZONE-3 | MECH | PW |
| CON-Z3-UT-PW-PL-0230 |  | Pipe Laying | 0.8d | 2016-12-26 | 2016-12-26 | CON-Z3-UT-PW-PL-0220, PR-Z3-UT-PW-121-0080 | 89.8d | 0d | Plumber [65 h]; Common Labor / Helper [39 h]; RTR Pipe Crew [26 h]; Operator - Mobile Crane [13 h]; Driver - Flat Bed Trailer [13 h]; Mobile Crane ( 25-60 Ton) [14 h]; Flat Bed Trailer [14 h] | 25,804.39 | 1.3.3.20 | CONS | CONS | ZONE-3 | MECH | PW |
| CON-Z3-UT-PW-PL-0240 |  | Installation of Thurst Block | 4d | 2016-12-26 | 2016-12-31 | CON-Z3-UT-PW-PL-0230 | 89.8d | 0d | Steel Fixer [26 h]; Shuttering Carpenter [52 h]; Concrete Mason [52 h]; Common Labor / Helper [52 h]; Driver - Conc. Transit Mixers [26 h]; Operator - Concrete Pump [26 h]; Concrete Transit Mixers [28 h]; Concrete Pump [28 h] | 8,601.46 | 1.3.3.20 | CONS | CONS | ZONE-3 | MECH | PW |
| CON-Z3-UT-PW-PL-0250 |  | Backfilling | 4d | 2016-12-31 | 2017-01-04 | CON-Z3-UT-PW-PL-0230, CON-Z3-UT-PW-PL-0240 | 89.8d | 4d | Common Labor / Helper [208 h]; Operator - Loader [52 h]; Driver - Dump Truck [52 h]; Operator - Bobcat [52 h]; Operator - Asphalt Compactor / Roller [52 h]; Operator - Roller-Compactor (2~10 Ton) [52 h]; Driver - Water Tanker [52 h]; Operator - JCB [52 h]; Loader [56 h]; Dump Truck [56 h]; Bobcat [56 h]; Roller-Compactor (2~10 Ton) [56 h]; Plate Compactor [56 h]; Vibrators [56 h]; Water Tanker [56 h]; JCB [56 h] | 12,902.2 | 1.3.3.20 | CONS | CONS | ZONE-3 | MECH | PW |
| CON-Z3-UT-PW-PL-0330 |  | Testing and Precommissioning | 4d | 2017-01-09 | 2017-01-14 | CON-Z3-UT-PW-PL-0250, CON-Z3-UT-PW-PL-0130 SS | 85.8d | 5.4d | Plumber [416 h]; Common Labor / Helper [260 h]; RTR Pipe Crew [104 h]; Driver - Water Tanker [10.4 h]; Water Tanker [11.2 h] | 17,202.93 | 1.3.3.20 | CONS | CONS | ZONE-3 | MECH | PW |

Notes:
- CON-Z3-UT-PW-PL-0260: Expenses: (New Expense Item) 86014.6
- CON-Z3-UT-PW-PL-0270: Expenses: (New Expense Item) 344059
- CON-Z3-UT-PW-PL-800: Expenses: (New Expense Item) 25804.4
- CON-Z3-UT-PW-PL-810: Expenses: (New Expense Item) 103218
- CON-Z3-UT-PW-PL-820: Expenses: (New Expense Item) 25804.4
- CON-Z3-UT-PW-PL-830: Expenses: (New Expense Item) 103218
- CON-Z3-UT-PW-PL-840: Expenses: (New Expense Item) 34405.9
- CON-Z3-UT-PW-PL-850: Expenses: (New Expense Item) 137623
- CON-Z3-UT-PW-PL-0070: Expenses: (New Expense Item) 12902.2
- CON-Z3-UT-PW-PL-0080: Expenses: (New Expense Item) 8601.46
- CON-Z3-UT-PW-PL-0090: Expenses: (New Expense Item) 25804.4
- CON-Z3-UT-PW-PL-0100: Expenses: (New Expense Item) 8601.46
- CON-Z3-UT-PW-PL-0110: Expenses: (New Expense Item) 12902.2
- CON-Z3-UT-PW-PL-0130: Expenses: (New Expense Item) 17202.9
- CON-Z3-UT-PW-PL-0210: Expenses: (New Expense Item) 12902.2
- CON-Z3-UT-PW-PL-0220: Expenses: (New Expense Item) 8601.46
- CON-Z3-UT-PW-PL-0230: Expenses: (New Expense Item) 25804.4
- CON-Z3-UT-PW-PL-0240: Expenses: (New Expense Item) 8601.46
- CON-Z3-UT-PW-PL-0250: Expenses: (New Expense Item) 12902.2
- CON-Z3-UT-PW-PL-0330: Expenses: (New Expense Item) 17202.9

| ID | WBS | Activity | Duration | Start | Finish | Predecessors | Total float | Free float | Resources | Cost | RPI_P2 - BOQ ITEMS | RPI_P2 - CONSTRUCTION | RPI_P2 - PHASE | RPI_P2 - ZONES | RPI_P2 - DISCIPLINE / WORK TYPE | RPI_P2 - UTILITY NETWORK |
| --- | --- | --- | --- | --- | --- | --- | --- | --- | --- | --- | --- | --- | --- | --- | --- | --- |
|  | 2 | **Potable Water Line - RTR 200mm dia at Road 3 = 189.9 Lm** |  | 2016-12-21 | 2017-01-21 |  |  |  |  |  |  |  |  |  |  |  |
| CON-Z3-UT-PW-PL-0280 |  | Excavation of Trench | 2.4d | 2016-12-21 | 2016-12-24 | CON-Z3-UT-PW-PL-0210 SS | 30.8d | 0d | Common Labor / Helper [93.6 h]; Operator - Excavator [31.2 h]; Driver - Dump Truck [31.2 h]; Operator - JCB [31.2 h]; Excavator [33.6 h]; Dump Truck [33.6 h] | 32,255.49 | 1.3.3.20 | CONS | CONS | ZONE-3 | MECH | PW |
| CON-Z3-UT-PW-PL-0290 |  | Compaction and Sand bedding | 1.6d | 2016-12-25 | 2016-12-26 | CON-Z3-UT-PW-PL-0280 SS+3.2d | 80.4d | 0d | Common Labor / Helper [104 h]; Operator - Loader [26 h]; Driver - Dump Truck [26 h]; Operator - Bobcat [26 h]; Operator - JCB [26 h] | 21,503.66 | 1.3.3.20 | CONS | CONS | ZONE-3 | MECH | PW |
| CON-Z3-UT-PW-PL-0300 |  | Pipe Laying | 4d | 2016-12-27 | 2017-01-01 | CON-Z3-UT-PW-PL-0290 SS+2.4d | 80.4d | 0d | Plumber [260 h]; Common Labor / Helper [208 h]; RTR Pipe Crew [104 h]; Operator - Mobile Crane [52 h]; Driver - Flat Bed Trailer [52 h]; Mobile Crane ( 25-60 Ton) [56 h]; Flat Bed Trailer [56 h] | 64,510.98 | 1.3.3.20 | CONS | CONS | ZONE-3 | MECH | PW |
| CON-Z3-UT-PW-PL-0310 |  | Installation of Thurst Block | 5.6d | 2017-01-01 | 2017-01-08 | CON-Z3-UT-PW-PL-0300 SS+4d | 80.4d | 0d | Steel Fixer [145.6 h]; Shuttering Carpenter [145.6 h]; Concrete Mason [145.6 h]; Common Labor / Helper [145.6 h]; Driver - Conc. Transit Mixers [36.4 h]; Operator - Concrete Pump [36.4 h]; Concrete Transit Mixers [39.2 h]; Concrete Pump [39.2 h] | 21,503.66 | 1.3.3.20 | CONS | CONS | ZONE-3 | MECH | PW |
| CON-Z3-UT-PW-PL-0320 |  | Backfilling | 7d | 2017-01-08 | 2017-01-16 | CON-Z3-UT-PW-PL-0310, CON-Z3-UT-PW-PL-0300 | 80.4d | 0d | Operator - Loader [91 h]; Driver - Dump Truck [91 h]; Operator - Bobcat [91 h]; Operator - Roller-Compactor (2~10 Ton) [91 h]; Driver - Water Tanker [91 h]; Operator - JCB [91 h]; Loader [98 h]; Dump Truck [98 h]; Bobcat [98 h]; Roller-Compactor (2~10 Ton) [98 h]; Plate Compactor [98 h]; Vibrators [98 h]; Water Tanker [98 h]; JCB [98 h]; Common Labor / Helper [364 h] | 32,255.49 | 1.3.3.20 | CONS | CONS | ZONE-3 | MECH | PW |
| CON-Z3-UT-PW-PL-0340 |  | Testing and Precommissioning | 4d | 2017-01-16 | 2017-01-21 | CON-Z3-UT-PW-PL-0320, CON-Z3-UT-PW-PL-0330 SS | 80.4d | 0d | Plumber [312 h]; Common Labor / Helper [208 h]; RTR Pipe Crew [52 h]; Driver - Water Tanker [10.4 h]; Water Tanker [11.2 h] | 43,007.32 | 1.3.3.20 | CONS | CONS | ZONE-3 | MECH | PW |
|  | 3 | **Potable Water Line - RTR 200mm dia at Road 4 = 72 Lm** |  | 2016-12-29 | 2017-01-18 |  |  |  |  |  |  |  |  |  |  |  |
| CON-Z3-UT-PW-PL-0370 |  | Excavation of Trench | 0.8d | 2016-12-29 | 2016-12-31 | CON-Z3-UT-PW-PL-0280 FS+5d | 30.8d | 0d | Common Labor / Helper [39 h]; Operator - Excavator [13 h]; Driver - Dump Truck [13 h]; Operator - JCB [13 h]; Excavator [14 h]; Dump Truck [14 h] | 19,353.29 | 1.3.3.20 | CONS | CONS | ZONE-3 | MECH | PW |
| CON-Z3-UT-PW-PL-0380 |  | Compaction and Sand bedding | 1.6d | 2016-12-31 | 2017-01-01 | CON-Z3-UT-PW-PL-0370 | 85.2d | 0d | Common Labor / Helper [41.6 h]; Operator - Loader [20.8 h]; Driver - Dump Truck [20.8 h]; Operator - Bobcat [20.8 h]; Operator - JCB [20.8 h]; Dump Truck [22.4 h]; JCB [22.4 h] | 12,902.2 | 1.3.3.20 | CONS | CONS | ZONE-3 | MECH | PW |
| CON-Z3-UT-PW-PL-0390 |  | Pipe Laying | 1.6d | 2017-01-01 | 2017-01-03 | CON-Z3-UT-PW-PL-0380 | 85.2d | 0d | Flat Bed Trailer [11.2 h]; Plumber [104 h]; Common Labor / Helper [62.4 h]; RTR Pipe Crew [41.6 h]; Operator - Mobile Crane [10.4 h]; Driver - Flat Bed Trailer [10.4 h]; Mobile Crane ( 25-60 Ton) [11.2 h] | 38,706.59 | 1.3.3.20 | CONS | CONS | ZONE-3 | MECH | PW |
| CON-Z3-UT-PW-PL-0400 |  | Installation of Thurst Block | 2d | 2017-01-03 | 2017-01-05 | CON-Z3-UT-PW-PL-0390 | 85.2d | 0d | Steel Fixer [26 h]; Shuttering Carpenter [52 h]; Concrete Mason [78 h]; Common Labor / Helper [130 h]; Driver - Conc. Transit Mixers [13 h]; Operator - Concrete Pump [13 h]; Concrete Transit Mixers [14 h]; Concrete Pump [14 h] | 12,902.2 | 1.3.3.20 | CONS | CONS | ZONE-3 | MECH | PW |
| CON-Z3-UT-PW-PL-0410 |  | Backfilling | 4d | 2017-01-05 | 2017-01-10 | CON-Z3-UT-PW-PL-0390, CON-Z3-UT-PW-PL-0400 | 85.2d | 4.8d | Common Labor / Helper [260 h]; Operator - Loader [26 h]; Driver - Dump Truck [26 h]; Operator - Bobcat [26 h]; Operator - Asphalt Compactor / Roller [26 h]; Operator - Roller-Compactor (2~10 Ton) [26 h]; Driver - Water Tanker [26 h]; Operator - JCB [26 h]; Loader [28 h]; Dump Truck [28 h]; Bobcat [28 h]; Roller-Compactor (2~10 Ton) [28 h]; Plate Compactor [28 h]; Vibrators [28 h]; Water Tanker [28 h]; JCB [28 h] | 19,353.29 | 1.3.3.20 | CONS | CONS | ZONE-3 | MECH | PW |
| CON-Z3-UT-PW-PL-0610 |  | Testing and Precommissioning | 2.4d | 2017-01-16 | 2017-01-18 | CON-Z3-UT-PW-PL-0340 SS, CON-Z3-UT-PW-PL-0410 | 80.4d | 0d | Plumber [156 h]; Common Labor / Helper [187.2 h]; RTR Pipe Crew [52 h]; Driver - Water Tanker [26 h]; Water Tanker [28 h] | 25,804.39 | 1.3.3.20 | CONS | CONS | ZONE-3 | MECH | PW |
|  | 9 | **Potable Water Line - RTR 100mm dia at Road 4 = 44 Lm** |  | 2017-01-05 | 2017-01-17 |  |  |  |  |  |  |  |  |  |  |  |
| CON-Z3-UT-PW-PL-410 |  | Excavation of Trench | 0.8d | 2017-01-05 | 2017-01-05 | CON-Z3-UT-PW-PL-0370 FS+5d | 30.8d | 0d | Common Labor / Helper [20.8 h]; Operator - Excavator [5.2 h]; Driver - Dump Truck [5.2 h]; Excavator [5.6 h]; Dump Truck [5.6 h] | 19,353.29 | 1.3.3.20 | CONS | CONS | ZONE-3 | MECH | PW |
| CON-Z3-UT-PW-PL-420 |  | Compaction and Sand bedding | 0.8d | 2017-01-07 | 2017-01-07 | CON-Z3-UT-PW-PL-410 | 84.4d | 0d | Common Labor / Helper [20.8 h]; Operator - Loader [13 h]; Driver - Dump Truck [13 h]; Operator - Bobcat [13 h]; Operator - JCB [13 h] | 12,902.2 | 1.3.3.20 | CONS | CONS | ZONE-3 | MECH | PW |
| CON-Z3-UT-PW-PL-430 |  | Pipe Laying | 0.8d | 2017-01-07 | 2017-01-08 | CON-Z3-UT-PW-PL-420 | 84.4d | 0d | Plumber [52 h]; Common Labor / Helper [78 h]; RTR Pipe Crew [52 h]; Operator - Mobile Crane [26 h]; Driver - Flat Bed Trailer [26 h]; Mobile Crane ( 25-60 Ton) [28 h]; Flat Bed Trailer [28 h] | 38,706.59 | 1.3.3.20 | CONS | CONS | ZONE-3 | MECH | PW |
| CON-Z3-UT-PW-PL-440 |  | Installation of Thurst Block | 1d | 2017-01-08 | 2017-01-09 | CON-Z3-UT-PW-PL-430 | 84.4d | 0d | Steel Fixer [26 h]; Shuttering Carpenter [52 h]; Concrete Mason [52 h]; Common Labor / Helper [52 h]; Driver - Conc. Transit Mixers [6.5 h]; Operator - Concrete Pump [6.5 h]; Concrete Transit Mixers [7 h]; Concrete Pump [7 h] | 12,902.2 | 1.3.3.20 | CONS | CONS | ZONE-3 | MECH | PW |
| CON-Z3-UT-PW-PL-450 |  | Backfilling | 1.6d | 2017-01-09 | 2017-01-11 | CON-Z3-UT-PW-PL-430, CON-Z3-UT-PW-PL-440 | 84.4d | 4d | Common Labor / Helper [52 h]; Operator - Loader [13 h]; Driver - Dump Truck [13 h]; Operator - Bobcat [13 h]; Operator - Asphalt Compactor / Roller [13 h]; Operator - Roller-Compactor (2~10 Ton) [13 h]; Driver - Water Tanker [13 h]; Operator - JCB [13 h]; Loader [14 h]; Dump Truck [14 h]; Bobcat [14 h]; Roller-Compactor (2~10 Ton) [14 h]; Plate Compactor [14 h]; Vibrators [14 h]; Water Tanker [14 h]; JCB [14 h] | 19,353.29 | 1.3.3.20 | CONS | CONS | ZONE-3 | MECH | PW |
| CON-Z3-UT-PW-PL-620 |  | Testing and Precommissioning | 1.6d | 2017-01-16 | 2017-01-17 | CON-Z3-UT-PW-PL-0610 SS, CON-Z3-UT-PW-PL-450 | 80.4d | 10d | Plumber [52 h]; Common Labor / Helper [52 h]; RTR Pipe Crew [52 h]; Driver - Water Tanker [26 h]; Water Tanker [28 h] | 25,804.39 | 1.3.3.20 | CONS | CONS | ZONE-3 | MECH | PW |
|  | 10 | **Potable Water Line - RTR 400mm dia at Road 5 = 85 Lm** |  | 2017-01-12 | 2017-01-30 |  |  |  |  |  |  |  |  |  |  |  |
| CON-Z3-UT-PW-PL-460 |  | Excavation of Trench | 0.8d | 2017-01-12 | 2017-01-12 | CON-Z3-UT-PW-PL-410 FS+5d | 30.8d | 0d | Common Labor / Helper [39 h]; Operator - Excavator [5.2 h]; Driver - Dump Truck [5.2 h]; Excavator [5.6 h]; Dump Truck [5.6 h] | 32,255.49 | 1.3.3.20 | CONS | CONS | ZONE-3 | MECH | PW |
| CON-Z3-UT-PW-PL-470 |  | Compaction and Sand bedding | 1.6d | 2017-01-16 | 2017-01-17 | CON-Z3-UT-PW-PL-460 SS+3.2d | 70.4d | 0d | Common Labor / Helper [52 h]; JCB [11.2 h]; Operator - JCB [10.4 h] | 21,503.66 | 1.3.3.20 | CONS | CONS | ZONE-3 | MECH | PW |
| CON-Z3-UT-PW-PL-480 |  | Pipe Laying | 1.6d | 2017-01-18 | 2017-01-21 | CON-Z3-UT-PW-PL-470 SS+2.4d | 70.4d | 0d | Plumber [52 h]; Common Labor / Helper [78 h]; RTR Pipe Crew [52 h]; Operator - Mobile Crane [10.4 h]; Driver - Flat Bed Trailer [10.4 h]; Mobile Crane ( 25-60 Ton) [11.2 h]; Flat Bed Trailer [11.2 h] | 64,510.98 | 1.3.3.20 | CONS | CONS | ZONE-3 | MECH | PW |
| CON-Z3-UT-PW-PL-490 |  | Installation of Thurst Block | 2d | 2017-01-21 | 2017-01-23 | CON-Z3-UT-PW-PL-480 | 70.4d | 0d | Steel Fixer [26 h]; Shuttering Carpenter [52 h]; Concrete Mason [52 h]; Common Labor / Helper [52 h]; Driver - Conc. Transit Mixers [13 h]; Operator - Concrete Pump [13 h]; Concrete Transit Mixers [14 h]; Concrete Pump [14 h] | 21,503.66 | 1.3.3.20 | CONS | CONS | ZONE-3 | MECH | PW |
| CON-Z3-UT-PW-PL-500 |  | Backfilling | 4d | 2017-01-23 | 2017-01-28 | CON-Z3-UT-PW-PL-480, CON-Z3-UT-PW-PL-490 | 70.4d | 0d | Common Labor / Helper [52 h]; Operator - Loader [13 h]; Driver - Dump Truck [13 h]; Operator - Bobcat [13 h]; Operator - Asphalt Compactor / Roller [13 h]; Operator - Roller-Compactor (2~10 Ton) [13 h]; Driver - Water Tanker [13 h]; Operator - JCB [13 h]; Loader [14 h]; Dump Truck [14 h]; Bobcat [14 h]; Roller-Compactor (2~10 Ton) [14 h]; Plate Compactor [14 h]; Vibrators [14 h]; Water Tanker [14 h]; JCB [14 h] | 32,255.49 | 1.3.3.20 | CONS | CONS | ZONE-3 | MECH | PW |
| CON-Z3-UT-PW-PL-630 |  | Testing and Precommissioning | 2.4d | 2017-01-28 | 2017-01-30 | CON-Z3-UT-PW-PL-620 SS, CON-Z3-UT-PW-PL-500 | 70.4d | 31.8d | Plumber [52 h]; Common Labor / Helper [52 h]; RTR Pipe Crew [52 h]; Driver - Water Tanker [26 h]; Water Tanker [28 h] | 43,007.32 | 1.3.3.20 | CONS | CONS | ZONE-3 | MECH | PW |

Notes:
- CON-Z3-UT-PW-PL-0280: Expenses: (New Expense Item) 32255.5
- CON-Z3-UT-PW-PL-0290: Expenses: (New Expense Item) 21503.7
- CON-Z3-UT-PW-PL-0300: Expenses: (New Expense Item) 64511
- CON-Z3-UT-PW-PL-0310: Expenses: (New Expense Item) 21503.7
- CON-Z3-UT-PW-PL-0320: Expenses: (New Expense Item) 32255.5
- CON-Z3-UT-PW-PL-0340: Expenses: (New Expense Item) 43007.3
- CON-Z3-UT-PW-PL-0370: Expenses: (New Expense Item) 19353.3
- CON-Z3-UT-PW-PL-0380: Expenses: (New Expense Item) 12902.2
- CON-Z3-UT-PW-PL-0390: Expenses: (New Expense Item) 38706.6
- CON-Z3-UT-PW-PL-0400: Expenses: (New Expense Item) 12902.2
- CON-Z3-UT-PW-PL-0410: Expenses: (New Expense Item) 19353.3
- CON-Z3-UT-PW-PL-0610: Expenses: (New Expense Item) 25804.4
- CON-Z3-UT-PW-PL-410: Expenses: (New Expense Item) 19353.3
- CON-Z3-UT-PW-PL-420: Expenses: (New Expense Item) 12902.2
- CON-Z3-UT-PW-PL-430: Expenses: (New Expense Item) 38706.6
- CON-Z3-UT-PW-PL-440: Expenses: (New Expense Item) 12902.2
- CON-Z3-UT-PW-PL-450: Expenses: (New Expense Item) 19353.3
- CON-Z3-UT-PW-PL-620: Expenses: (New Expense Item) 25804.4
- CON-Z3-UT-PW-PL-460: Expenses: (New Expense Item) 32255.5
- CON-Z3-UT-PW-PL-470: Expenses: (New Expense Item) 21503.7
- CON-Z3-UT-PW-PL-480: Expenses: (New Expense Item) 64511
- CON-Z3-UT-PW-PL-490: Expenses: (New Expense Item) 21503.7
- CON-Z3-UT-PW-PL-500: Expenses: (New Expense Item) 32255.5
- CON-Z3-UT-PW-PL-630: Expenses: (New Expense Item) 43007.3

| ID | WBS | Activity | Duration | Start | Finish | Predecessors | Total float | Free float | Resources | Cost | RPI_P2 - BOQ ITEMS | RPI_P2 - CONSTRUCTION | RPI_P2 - PHASE | RPI_P2 - ZONES | RPI_P2 - DISCIPLINE / WORK TYPE | RPI_P2 - UTILITY NETWORK |
| --- | --- | --- | --- | --- | --- | --- | --- | --- | --- | --- | --- | --- | --- | --- | --- | --- |
|  | 11 | **Potable Water Line - RTR 350mm dia at Road 5 = 680 Lm** |  | 2017-01-18 | 2017-03-14 |  |  |  |  |  |  |  |  |  |  |  |
| CON-Z3-UT-PW-PL-510 |  | Excavation of Trench | 4.8d | 2017-01-18 | 2017-01-24 | CON-Z3-UT-PW-PL-460 FS+5d | 30.8d | 0d | Common Labor / Helper [124.8 h]; Driver - Dump Truck [31.2 h]; Operator - JCB [31.2 h]; Dump Truck [33.6 h]; JCB [33.6 h] | 96,766.47 | 1.3.3.20 | CONS | CONS | ZONE-3 | MECH | PW |
| CON-Z3-UT-PW-PL-520 |  | Compaction and Sand bedding | 3.2d | 2017-01-23 | 2017-01-26 | CON-Z3-UT-PW-PL-510 SS+3.2d | 38.6d | 0d | Common Labor / Helper [166.4 h]; Operator - JCB [20.8 h]; JCB [22.4 h] | 64,510.98 | 1.3.3.20 | CONS | CONS | ZONE-3 | MECH | PW |
| CON-Z3-UT-PW-PL-530 |  | Pipe Laying | 13.6d | 2017-01-25 | 2017-02-09 | CON-Z3-UT-PW-PL-520 SS+2.4d | 38.6d | 0d | Plumber [530.4 h]; Common Labor / Helper [353.6 h]; RTR Pipe Crew [176.8 h]; Operator - Mobile Crane [88.4 h]; Driver - Flat Bed Trailer [88.4 h]; Mobile Crane ( 25-60 Ton) [95.2 h]; Flat Bed Trailer [95.2 h] | 193,532.94 | 1.3.3.20 | CONS | CONS | ZONE-3 | MECH | PW |
| CON-Z3-UT-PW-PL-540 |  | Installation of Thurst Block | 5d | 2017-01-30 | 2017-02-05 | CON-Z3-UT-PW-PL-530 SS+4d | 43.2d | 4.6d | Steel Fixer [26 h]; Shuttering Carpenter [52 h]; Concrete Mason [52 h]; Common Labor / Helper [52 h]; Driver - Conc. Transit Mixers [26 h]; Operator - Concrete Pump [26 h]; Concrete Transit Mixers [28 h]; Concrete Pump [28 h] | 64,510.98 | 1.3.3.20 | CONS | CONS | ZONE-3 | MECH | PW |
| CON-Z3-UT-PW-PL-550 |  | Backfilling | 20d | 2017-02-11 | 2017-03-05 | CON-Z3-UT-PW-PL-530, CON-Z3-UT-PW-PL-540 | 38.6d | 0d | Common Labor / Helper [104 h]; Operator - Loader [200 h]; Driver - Dump Truck [200 h]; Operator - Bobcat [200 h]; Operator - Roller-Compactor (2~10 Ton) [200 h]; Driver - Water Tanker [200 h]; Operator - JCB [200 h]; Loader [280 h]; Dump Truck [280 h]; Bobcat [280 h]; Roller-Compactor (2~10 Ton) [280 h]; Plate Compactor [280 h]; Vibrators [280 h]; Water Tanker [280 h]; JCB [280 h] | 96,766.47 | 1.3.3.20 | CONS | CONS | ZONE-3 | MECH | PW |
| CON-Z3-UT-PW-PL-640 |  | Testing and Precommissioning | 8d | 2017-03-06 | 2017-03-14 | CON-Z3-UT-PW-PL-630 SS, CON-Z3-UT-PW-PL-550 | 38.6d | 0d | Plumber [800 h]; Common Labor / Helper [52 h]; RTR Pipe Crew [52 h]; Driver - Water Tanker [26 h]; Water Tanker [28 h] | 129,021.96 | 1.3.3.20 | CONS | CONS | ZONE-3 | MECH | PW |
|  | 12 | **Potable Water Line - RTR 300mm dia at Road 5 = 111 Lm** |  | 2017-01-30 | 2017-03-22 |  |  |  |  |  |  |  |  |  |  |  |
| CON-Z3-UT-PW-PL-560 |  | Excavation of Trench | 0.8d | 2017-01-30 | 2017-01-31 | CON-Z3-UT-PW-PL-510 FS+5d | 30.8d | 0d | Common Labor / Helper [39 h]; Operator - Excavator [13 h]; Driver - Dump Truck [13 h]; Operator - JCB [13 h]; Excavator [14 h]; Dump Truck [14 h] | 32,255.49 | 1.3.3.20 | CONS | CONS | ZONE-3 | MECH | PW |
| CON-Z3-UT-PW-PL-570 |  | Compaction and Sand bedding | 1.6d | 2017-02-02 | 2017-02-05 | CON-Z3-UT-PW-PL-560 SS+3.2d | 59.2d | 0d | Common Labor / Helper [52 h]; Operator - Loader [20.8 h]; Driver - Dump Truck [20.8 h]; Operator - Bobcat [20.8 h]; Operator - JCB [20.8 h]; Dump Truck [22.4 h] | 21,503.66 | 1.3.3.20 | CONS | CONS | ZONE-3 | MECH | PW |
| CON-Z3-UT-PW-PL-580 |  | Pipe Laying | 2.4d | 2017-02-06 | 2017-02-08 | CON-Z3-UT-PW-PL-570 SS+2.4d | 59.2d | 0d | Plumber [124.8 h]; Common Labor / Helper [78 h]; RTR Pipe Crew [52 h]; Operator - Mobile Crane [26 h]; Driver - Flat Bed Trailer [26 h]; Mobile Crane ( 25-60 Ton) [28 h]; Flat Bed Trailer [28 h] | 64,510.98 | 1.3.3.20 | CONS | CONS | ZONE-3 | MECH | PW |
| CON-Z3-UT-PW-PL-590 |  | Installation of Thurst Block | 3.2d | 2017-02-11 | 2017-02-14 | CON-Z3-UT-PW-PL-580 SS+4d | 59.2d | 0d | Steel Fixer [166.4 h]; Shuttering Carpenter [166.4 h]; Concrete Mason [166.4 h]; Common Labor / Helper [332.8 h]; Driver - Conc. Transit Mixers [41.6 h]; Operator - Concrete Pump [41.6 h]; Concrete Transit Mixers [44.8 h]; Concrete Pump [44.8 h] | 21,503.66 | 1.3.3.20 | CONS | CONS | ZONE-3 | MECH | PW |
| CON-Z3-UT-PW-PL-600 |  | Backfilling | 4d | 2017-02-14 | 2017-02-19 | CON-Z3-UT-PW-PL-590, CON-Z3-UT-PW-PL-580 | 59.2d | 20.6d | Common Labor / Helper [260 h]; Operator - Loader [52 h]; Driver - Dump Truck [52 h]; Operator - Bobcat [52 h]; Operator - Asphalt Compactor / Roller [52 h]; Operator - Roller-Compactor (2~10 Ton) [52 h]; Driver - Water Tanker [52 h]; Operator - JCB [52 h]; Loader [56 h]; Dump Truck [56 h]; Bobcat [56 h]; Roller-Compactor (2~10 Ton) [56 h]; Plate Compactor [56 h]; Vibrators [56 h]; Water Tanker [56 h]; JCB [56 h] | 32,255.49 | 1.3.3.20 | CONS | CONS | ZONE-3 | MECH | PW |
| CON-Z3-UT-PW-PL-650 |  | Testing and Precommissioning | 6.4d | 2017-03-15 | 2017-03-22 | CON-Z3-UT-PW-PL-600, CON-Z3-UT-PW-PL-640 | 38.6d | 0d | Plumber [640 h]; Common Labor / Helper [52 h]; RTR Pipe Crew [52 h]; Driver - Water Tanker [26 h]; Water Tanker [28 h] | 43,007.32 | 1.3.3.20 | CONS | CONS | ZONE-3 | MECH | PW |
|  | 14 | **Potable Water Line - Upvc 50mm dia at Realm Area = 128 Lm** |  | 2017-01-31 | 2017-05-07 |  |  |  |  |  |  |  |  |  |  |  |
| CON-Z3-UT-PW-PL-660 |  | Excavation of Trench | 2d | 2017-01-31 | 2017-02-02 | CON-Z3-UT-PW-PL-560 | 30.8d | 0d | Common Labor / Helper [104 h]; Operator - Excavator [26 h]; Driver - Dump Truck [26 h]; Operator - JCB [26 h]; Excavator [28 h]; Dump Truck [28 h] | 32,255.49 | 1.3.3.20 | CONS | CONS | ZONE-3 | MECH | PW |
| CON-Z3-UT-PW-PL-670 |  | Compaction and Sand bedding | 1.6d | 2017-02-04 | 2017-02-06 | CON-Z3-UT-PW-PL-660 SS+3.2d | 98.8d | 0d | Common Labor / Helper [104 h]; Operator - Loader [20.8 h]; Driver - Dump Truck [20.8 h]; Operator - Bobcat [20.8 h]; Operator - JCB [20.8 h]; Dump Truck [22.4 h]; JCB [22.4 h]; Loader [22.4 h] | 21,503.66 | 1.3.3.20 | CONS | CONS | ZONE-3 | MECH | PW |
| CON-Z3-UT-PW-PL-680 |  | Pipe Laying | 3d | 2017-02-07 | 2017-02-09 | CON-Z3-UT-PW-PL-670 SS+2.4d | 98.8d | 0d | Plumber [195 h]; Common Labor / Helper [195 h]; RTR Pipe Crew [52 h]; Operator - Mobile Crane [26 h]; Driver - Flat Bed Trailer [26 h]; Mobile Crane ( 25-60 Ton) [28 h]; Flat Bed Trailer [28 h] | 64,510.98 | 1.3.3.20 | CONS | CONS | ZONE-3 | MECH | PW |
| CON-Z3-UT-PW-PL-690 |  | Installation of Thurst Block | 3.2d | 2017-02-12 | 2017-02-15 | CON-Z3-UT-PW-PL-680 SS+4d | 98.8d | 0d | Steel Fixer [166.4 h]; Shuttering Carpenter [166.4 h]; Concrete Mason [166.4 h]; Common Labor / Helper [208 h]; Driver - Conc. Transit Mixers [26 h]; Operator - Concrete Pump [26 h]; Concrete Transit Mixers [28 h]; Concrete Pump [28 h] | 21,503.66 | 1.3.3.20 | CONS | CONS | ZONE-3 | MECH | PW |
| CON-Z3-UT-PW-PL-700 |  | Backfilling | 5d | 2017-02-15 | 2017-02-21 | CON-Z3-UT-PW-PL-680, CON-Z3-UT-PW-PL-690 | 98.8d | 60.2d | Common Labor / Helper [260 h]; Operator - Loader [65 h]; Driver - Dump Truck [65 h]; Operator - Bobcat [65 h]; Operator - Asphalt Compactor / Roller [65 h]; Operator - Roller-Compactor (2~10 Ton) [65 h]; Driver - Water Tanker [65 h]; Operator - JCB [65 h]; Loader [70 h]; Dump Truck [70 h]; Bobcat [70 h]; Roller-Compactor (2~10 Ton) [70 h]; Plate Compactor [70 h]; Vibrators [70 h]; Water Tanker [70 h]; JCB [70 h] | 32,255.49 | 1.3.3.20 | CONS | CONS | ZONE-3 | MECH | PW |
| CON-Z3-UT-PW-PL-780 |  | Testing and Precommissioning | 4d | 2017-05-02 | 2017-05-07 | CON-Z3-UT-PW-PL-650 FS+35d, CON-Z3-UT-PW-PL-700 | 38.6d | 0d | Plumber [400 h]; Common Labor / Helper [400 h]; RTR Pipe Crew [52 h]; Driver - Water Tanker [26 h]; Water Tanker [28 h] | 43,007.32 | 1.3.3.20 | CONS | CONS | ZONE-3 | MECH | PW |
|  | 15 | **Potable Water Line - Upvc 25mm dia at Realm Area = 576 Lm** |  | 2017-02-02 | 2017-05-16 |  |  |  |  |  |  |  |  |  |  |  |
| CON-Z3-UT-PW-PL-710 |  | Excavation of Trench | 4d | 2017-02-02 | 2017-02-07 | CON-Z3-UT-PW-PL-660 | 30.8d | 0d | Common Labor / Helper [208 h]; Driver - Dump Truck [52 h]; Operator - JCB [52 h]; Dump Truck [56 h]; JCB [56 h] | 96,766.47 | 1.3.3.20 | CONS | CONS | ZONE-3 | MECH | PW |
| CON-Z3-UT-PW-PL-720 |  | Compaction and Sand bedding | 3.2d | 2017-02-06 | 2017-02-09 | CON-Z3-UT-PW-PL-710 SS+3.2d | 86.8d | 0d | Common Labor / Helper [156 h]; Operator - Loader [39 h]; Driver - Dump Truck [39 h]; Operator - Bobcat [39 h]; Operator - JCB [39 h] | 64,510.98 | 1.3.3.20 | CONS | CONS | ZONE-3 | MECH | PW |
| CON-Z3-UT-PW-PL-730 |  | Pipe Laying | 11.2d | 2017-02-09 | 2017-02-22 | CON-Z3-UT-PW-PL-720 SS+2.4d | 86.8d | 0d | Mobile Crane ( 25-60 Ton) [156.8 h]; Flat Bed Trailer [156.8 h]; Plumber [728 h]; Common Labor / Helper [582.4 h]; RTR Pipe Crew [291.2 h]; Operator - Mobile Crane [145.6 h]; Driver - Flat Bed Trailer [145.6 h] | 193,532.94 | 1.3.3.20 | CONS | CONS | ZONE-3 | MECH | PW |
| CON-Z3-UT-PW-PL-740 |  | Installation of Thurst Block | 5d | 2017-02-14 | 2017-02-19 | CON-Z3-UT-PW-PL-730 SS+4d | 89d | 2.2d | Steel Fixer [260 h]; Shuttering Carpenter [260 h]; Concrete Mason [260 h]; Common Labor / Helper [325 h]; Driver - Conc. Transit Mixers [65 h]; Operator - Concrete Pump [65 h]; Concrete Transit Mixers [70 h]; Concrete Pump [70 h] | 64,510.98 | 1.3.3.20 | CONS | CONS | ZONE-3 | MECH | PW |
| CON-Z3-UT-PW-PL-750 |  | Backfilling | 15d | 2017-02-22 | 2017-03-12 | CON-Z3-UT-PW-PL-740, CON-Z3-UT-PW-PL-730 | 86.8d | 48.2d | Common Labor / Helper [104 h]; Operator - Loader [150 h]; Driver - Dump Truck [150 h]; Operator - Bobcat [150 h]; Operator - Asphalt Compactor / Roller [150 h]; Operator - Roller-Compactor (2~10 Ton) [150 h]; Driver - Water Tanker [150 h]; Operator - JCB [150 h]; Loader [210 h]; Dump Truck [210 h]; Bobcat [840 h]; Roller-Compactor (2~10 Ton) [210 h]; Plate Compactor [210 h]; Vibrators [210 h]; Water Tanker [210 h]; JCB [210 h] | 96,766.47 | 1.3.3.20 | CONS | CONS | ZONE-3 | MECH | PW |
| CON-Z3-UT-PW-PL-790 |  | Testing and Precommissioning | 8d | 2017-05-07 | 2017-05-16 | CON-Z3-UT-PW-PL-780, CON-Z3-UT-PW-PL-750 | 38.6d | 0d | Plumber [400 h]; Common Labor / Helper [800 h]; RTR Pipe Crew [52 h]; Driver - Water Tanker [26 h]; Water Tanker [28 h] | 129,021.96 | 1.3.3.20 | CONS | CONS | ZONE-3 | MECH | PW |

Notes:
- CON-Z3-UT-PW-PL-510: Expenses: (New Expense Item) 96766.5
- CON-Z3-UT-PW-PL-520: Expenses: (New Expense Item) 64511
- CON-Z3-UT-PW-PL-530: Expenses: (New Expense Item) 193533
- CON-Z3-UT-PW-PL-540: Expenses: (New Expense Item) 64511
- CON-Z3-UT-PW-PL-550: Expenses: (New Expense Item) 96766.5
- CON-Z3-UT-PW-PL-640: Expenses: (New Expense Item) 129022
- CON-Z3-UT-PW-PL-560: Expenses: (New Expense Item) 32255.5
- CON-Z3-UT-PW-PL-570: Expenses: (New Expense Item) 21503.7
- CON-Z3-UT-PW-PL-580: Expenses: (New Expense Item) 64511
- CON-Z3-UT-PW-PL-590: Expenses: (New Expense Item) 21503.7
- CON-Z3-UT-PW-PL-600: Expenses: (New Expense Item) 32255.5
- CON-Z3-UT-PW-PL-650: Expenses: (New Expense Item) 43007.3
- CON-Z3-UT-PW-PL-660: Expenses: (New Expense Item) 32255.5
- CON-Z3-UT-PW-PL-670: Expenses: (New Expense Item) 21503.7
- CON-Z3-UT-PW-PL-680: Expenses: (New Expense Item) 64511
- CON-Z3-UT-PW-PL-690: Expenses: (New Expense Item) 21503.7
- CON-Z3-UT-PW-PL-700: Expenses: (New Expense Item) 32255.5
- CON-Z3-UT-PW-PL-780: Expenses: (New Expense Item) 43007.3
- CON-Z3-UT-PW-PL-710: Expenses: (New Expense Item) 96766.5
- CON-Z3-UT-PW-PL-720: Expenses: (New Expense Item) 64511
- CON-Z3-UT-PW-PL-730: Expenses: (New Expense Item) 193533
- CON-Z3-UT-PW-PL-740: Expenses: (New Expense Item) 64511
- CON-Z3-UT-PW-PL-750: Expenses: (New Expense Item) 96766.5
- CON-Z3-UT-PW-PL-790: Expenses: (New Expense Item) 129022

| ID | WBS | Activity | Duration | Start | Finish | Predecessors | Total float | Free float | Resources | Cost | RPI_P2 - BOQ ITEMS | RPI_P2 - CONSTRUCTION | RPI_P2 - PHASE | RPI_P2 - ZONES | RPI_P2 - DISCIPLINE / WORK TYPE | RPI_P2 - UTILITY NETWORK | Activity Wt% | Weight % | Cost Wt | RPI - PHASE | RPI - CONSTRUCTION | RPI - ZONES | RPI - UTILITY NETWORKS | RPI - TYPE OF WORK | RPI_P2 - AREAS |
| --- | --- | --- | --- | --- | --- | --- | --- | --- | --- | --- | --- | --- | --- | --- | --- | --- | --- | --- | --- | --- | --- | --- | --- | --- | --- |
|  | 13 | **Fire Hydrants and Accessories** |  | 2017-05-07 | 2017-05-31 |  |  |  |  |  |  |  |  |  |  |  |  |  |  |  |  |  |  |  |  |
| CON-Z3-UT-PW-FH-010 |  | Insttaltion of Fire Hydrants including Break Check Values and Accessories | 15d | 2017-05-07 | 2017-05-24 | PR-Z3-UT-PW-123-0080, CON-Z3-UT-PW-PL-790 SS | 38.6d | 0d | Plumber [150 h]; Common Labor / Helper [150 h]; Specialist Works Crew [150 h] | 80,836.27 | 1.3.3.20 | CONS | CONS | ZONE-3 | MECH | PW |  |  |  |  |  |  |  |  |  |
| CON-Z3-UT-PW-FH-020 |  | Instalaltion of Gate Valves Direct Burried with Extension Spindle & Surface Box | 15d | 2017-05-11 | 2017-05-29 | PR-Z3-UT-PW-144-0080, CON-Z3-UT-PW-FH-010 SS+4d, PR-Z3-UT-PW-124-0080 | 38.6d | 0d | Plumber [150 h]; Common Labor / Helper [75 h]; Specialist Works Crew [150 h] | 60,627.2 | 1.3.3.20 | CONS | CONS | ZONE-3 | MECH | PW |  |  |  |  |  |  |  |  |  |
| CON-Z3-UT-PW-FH-030 |  | Instalaltion of Metallic Flanges, Pipe & Fittings for Fire Hydrants | 15d | 2017-05-11 | 2017-05-29 | PR-Z3-UT-PW-125-0080, CON-Z3-UT-PW-FH-010 SS+4d | 38.6d | 0d | Plumber [26 h]; Common Labor / Helper [52 h]; Specialist Works Crew [26 h] | 60,627.2 | 1.3.3.20 | CONS | CONS | ZONE-3 | MECH | PW |  |  |  |  |  |  |  |  |  |
| CON-Z3-UT-PW-FH-040 |  | Installation of Guard Post for Fire Hydrants | 13d | 2017-05-16 | 2017-05-31 | PR-Z3-UT-PW-126-0080, CON-Z3-UT-PW-FH-020 SS+4d, CON-Z3-UT-PW-FH-030 SS+4d | 38.6d | 4.2d | Plumber [26 h]; Common Labor / Helper [52 h]; Specialist Works Crew [26 h] | 40,418.14 | 1.3.3.20 | CONS | CONS | ZONE-3 | MECH | PW |  |  |  |  |  |  |  |  |  |
|  | 2 | **Potable and Fire Water Chambers** |  | 2017-02-22 | 2017-06-01 |  |  |  |  |  |  |  |  |  |  |  |  |  |  |  |  |  |  |  |  |
|  | 2 | **Chamber - New VB Type C at Road A** |  | 2017-02-22 | 2017-03-23 |  |  |  |  |  |  |  |  |  |  |  |  |  |  |  |  |  |  |  |  |
| CON-Z3-UT-PW-VC-0010 |  | Excavation and Compaction | 1.6d | 2017-02-22 | 2017-02-23 | CON-Z3-UT-PW-PL-710 FS+13d | 30.8d | 0d | Operator - Excavator [26 h]; Excavator [44.8 h]; Common Labor / Helper [62.4 h] | 5,759.91 | 1.3.3.20 | CONS | CONS | ZONE-3 | MECH | PW | 0 | 0 | 0.0030836221 | 6 | RPI - CONS | Z2 | PW | MECH | ROAD-A |
| CON-Z3-UT-PW-VC-0020 |  | Lean concrete | 0.8d | 2017-02-25 | 2017-02-25 | PR-Z3-CW-CW-24-0080, CON-Z3-UT-PW-VC-0010 | 40.8d | 0d | Concrete Mason [52 h]; Driver - Conc. Transit Mixers [26 h]; Operator - Concrete Pump [26 h]; Common Labor / Helper [52 h] | 3,455.95 | 1.3.3.20 | CONS | CONS | ZONE-3 | MECH | PW | 0 | 0 | 0.0003088871 | 6 | RPI - CONS | Z2 | PW | MECH | ROAD-A |
| CON-Z3-UT-PW-VC-0030 |  | Formwork for Base Slab | 0.8d | 2017-02-25 | 2017-02-26 | CON-Z3-UT-PW-VC-0020 | 40.8d | 0d | Shuttering Carpenter [78 h]; Common Labor / Helper [52 h] | 5,759.91 | 1.3.3.20 | CONS | CONS | ZONE-3 | MECH | PW | 0 | 0 | 0.000308358 | 6 | RPI - CONS | Z2 | PW | MECH | ROAD-A |
| CON-Z3-UT-PW-VC-0040 |  | Fabrication & installation of Rebar for Base Slab | 4d | 2017-02-26 | 2017-03-02 | PR-Z3-CW-CW-25-0080, CON-Z3-UT-PW-VC-0030 | 40.8d | 0d | Steel Fixer [312 h] | 5,759.91 | 1.3.3.20 | CONS | CONS | ZONE-3 | MECH | PW | 0 | 0 | 0.0015418111 | 6 | RPI - CONS | Z2 | PW | MECH | ROAD-A |
| CON-Z3-UT-PW-VC-0050 |  | Fabrication & installation of Rebar for Side walls | 4d | 2017-03-02 | 2017-03-07 | CON-Z3-UT-PW-VC-0040 | 40.8d | 0d | Steel Fixer [320 h] | 5,759.91 | 1.3.3.20 | CONS | CONS | ZONE-3 | MECH | PW | 0 | 0 | 0.0030836221 | 6 | RPI - CONS | Z2 | PW | MECH | ROAD-A |
| CON-Z3-UT-PW-VC-0060 |  | Formwork for side walls | 4d | 2017-03-04 | 2017-03-08 | CON-Z3-UT-PW-VC-0050 SS+0.8d | 40.8d | 0d | Shuttering Carpenter [400 h]; Common Labor / Helper [26 h]; Scaffolder [52 h] | 5,759.91 | 1.3.3.20 | CONS | CONS | ZONE-3 | MECH | PW | 0 | 0 | 0.0015418111 | 6 | RPI - CONS | Z2 | PW | MECH | ROAD-A |
| CON-Z3-UT-PW-VC-0070 |  | Concrete pouring for base slab | 0.8d | 2017-03-08 | 2017-03-09 | CON-Z3-UT-PW-VC-0060, PR-Z3-CW-CW-24-0080 | 40.8d | 0d | Concrete Mason [20.8 h]; Common Labor / Helper [26 h]; Finishing Work Crew [10.4 h]; Driver - Conc. Transit Mixers [26 h]; Operator - Concrete Pump [26 h]; Concrete Transit Mixers [28 h]; Concrete Pump [28 h] | 11,519.82 | 1.3.3.20 | CONS | CONS | ZONE-3 | MECH | PW | 0 | 0 | 0.0015418111 | 6 | RPI - CONS | Z2 | PW | MECH | ROAD-A |
| CON-Z3-UT-PW-VC-0080 |  | Concrete pouring for Side Wall | 0.8d | 2017-03-09 | 2017-03-09 | CON-Z3-UT-PW-VC-0070 | 40.8d | 0d | Concrete Mason [20.8 h]; Common Labor / Helper [26 h]; Finishing Work Crew [10.4 h]; Driver - Conc. Transit Mixers [26 h]; Operator - Concrete Pump [26 h] | 11,519.82 | 1.3.3.20 | CONS | CONS | ZONE-3 | MECH | PW | 0 | 0 | 0.0040086961 | 6 | RPI - CONS | Z2 | PW | MECH | ROAD-A |
| CON-Z3-UT-PW-VC-0090 |  | Formwork removal and concrete patching | 1.6d | 2017-03-11 | 2017-03-12 | CON-Z3-UT-PW-VC-0080 | 40.8d | 0d | Shuttering Carpenter [78 h]; Scaffolder [26 h]; Finishing Work Crew [52 h] | 2,303.96 | 1.3.3.20 | CONS | CONS | ZONE-3 | MECH | PW | 0 | 0 | 0.0015418111 | 6 | RPI - CONS | Z2 | PW | MECH | ROAD-A |
| CON-Z3-UT-PW-VC-0100 |  | Concrete Supports | 0.8d | 2017-03-12 | 2017-03-13 | CON-Z3-UT-PW-VC-0090 | 40.8d | 0d | Shuttering Carpenter [26 h]; Concrete Mason [26 h]; Common Labor / Helper [26 h] | 17,279.73 | 1.3.3.20 | CONS | CONS | ZONE-3 | MECH | PW | 0 | 0 | 0.000616716 | 6 | RPI - CONS | Z2 | PW | MECH | ROAD-A |
| CON-Z3-UT-PW-VC-0110 |  | Installation of Pipe Connections / Closing of Openings | 3.2d | 2017-03-13 | 2017-03-16 | PR-Z3-UT-PW-129-0080, CON-Z3-UT-PW-VC-0100 | 40.8d | 0d | Shuttering Carpenter [26 h]; Concrete Mason [26 h]; Plumber [160 h]; Common Labor / Helper [26 h] | 3,455.95 | 1.3.3.20 | CONS | CONS | ZONE-3 | MECH | PW | 0 | 0 | 0.0055505071 | 6 | RPI - CONS | Z2 | PW | MECH | ROAD-A |
| CON-Z3-UT-PW-VC-0560 |  | Instalaltion of Dismantling Joints | 2.4d | 2017-03-13 | 2017-03-15 | CON-Z3-UT-PW-VC-0110 SS, PR-Z3-UT-PW-127-0080 | 40.8d | 0d | Common Labor / Helper [26 h]; RTR Pipe Crew [26 h] | 5,759.91 | 1.3.3.20 | CONS | CONS | ZONE-3 | MECH | PW |  |  |  |  |  |  |  |  | ROAD-A |
| CON-Z3-UT-PW-VC-0570 |  | Instalaltion of Gate Valves | 2.4d | 2017-03-15 | 2017-03-18 | PR-Z3-UT-PW-124-0080, CON-Z3-UT-PW-VC-0560 SS+1.6d | 40.8d | 0d | Common Labor / Helper [26 h]; RTR Pipe Crew [26 h]; Specialist Works Crew [26 h] | 5,759.91 | 1.3.3.20 | CONS | CONS | ZONE-3 | MECH | PW |  |  |  |  |  |  |  |  | ROAD-A |
| CON-Z3-UT-PW-VC-0120 |  | Damp Proof Coating | 0.8d | 2017-03-16 | 2017-03-18 | CON-Z3-UT-PW-VC-0090, CON-Z3-UT-PW-VC-0110 | 41.6d | 0d | Painter [52 h]; Water Proofing Crew [52 h] | 2,303.96 | 1.3.3.20 | CONS | CONS | ZONE-3 | MECH | PW | 0 | 0 | 0.0015418111 | 6 | RPI - CONS | Z2 | PW | MECH | ROAD-A |
| CON-Z3-UT-PW-VC-0580 |  | Instalallation of Pressure Guage | 1.6d | 2017-03-16 | 2017-03-19 | CON-Z3-UT-PW-VC-0570 SS+1.6d | 40.8d | 0d | Common Labor / Helper [26 h] | 9,215.85 | 1.3.3.20 | CONS | CONS | ZONE-3 | MECH | PW |  |  |  |  |  |  |  |  | ROAD-A |
| CON-Z3-UT-PW-VC-0130 |  | Backfilling & Compaction | 4d | 2017-03-18 | 2017-03-22 | PR-Z3-CW-CW-26-0080, CON-Z3-UT-PW-VC-0120 | 41.6d | 0.8d | Common Labor / Helper [52 h]; Driver - Dump Truck [26 h]; Operator - Bobcat [26 h]; Operator - Roller-Compactor (2~10 Ton) [26 h]; Driver - Water Tanker [26 h]; Operator - JCB [26 h]; Bobcat [28 h]; Plate Compactor [28 h]; Vibrators [28 h]; Water Tanker [28 h]; JCB [28 h] | 5,759.91 | 1.3.3.20 | CONS | CONS | ZONE-3 | MECH | PW | 0 | 0 | 0.0037003381 | 6 | RPI - CONS | Z2 | PW | MECH | ROAD-A |
| CON-Z3-UT-PW-VC-0910 |  | Installation of Roof Slab, Manhole Cover, Accessories & Finishes | 4d | 2017-03-19 | 2017-03-23 | CON-Z3-UT-PW-VC-0130 SS, CON-Z3-UT-PW-VC-0580 | 40.8d | 10d | Common Labor / Helper [52 h]; Finishing Work Crew [52 h] | 8,063.87 | 1.3.3.20 | CONS | CONS | ZONE-3 | MECH | PW |  |  |  |  |  |  |  |  | ROAD-A |

Notes:
- CON-Z3-UT-PW-FH-010: Expenses: (New Expense Item) 80836.3
- CON-Z3-UT-PW-FH-020: Expenses: (New Expense Item) 60627.2
- CON-Z3-UT-PW-FH-030: Expenses: (New Expense Item) 60627.2
- CON-Z3-UT-PW-FH-040: Expenses: (New Expense Item) 40418.1
- CON-Z3-UT-PW-VC-0010: Expenses: (New Expense Item) 5759.91
- CON-Z3-UT-PW-VC-0020: Expenses: (New Expense Item) 3455.95
- CON-Z3-UT-PW-VC-0030: Expenses: (New Expense Item) 5759.91
- CON-Z3-UT-PW-VC-0040: Expenses: (New Expense Item) 5759.91
- CON-Z3-UT-PW-VC-0050: Expenses: (New Expense Item) 5759.91
- CON-Z3-UT-PW-VC-0060: Expenses: (New Expense Item) 5759.91
- CON-Z3-UT-PW-VC-0070: Expenses: (New Expense Item) 11519.8
- CON-Z3-UT-PW-VC-0080: Expenses: (New Expense Item) 11519.8
- CON-Z3-UT-PW-VC-0090: Expenses: (New Expense Item) 2303.96
- CON-Z3-UT-PW-VC-0100: Expenses: (New Expense Item) 17279.7
- CON-Z3-UT-PW-VC-0110: Expenses: (New Expense Item) 3455.95
- CON-Z3-UT-PW-VC-0560: Expenses: (New Expense Item) 5759.91
- CON-Z3-UT-PW-VC-0570: Expenses: (New Expense Item) 5759.91
- CON-Z3-UT-PW-VC-0120: Expenses: (New Expense Item) 2303.96
- CON-Z3-UT-PW-VC-0580: Expenses: (New Expense Item) 9215.85
- CON-Z3-UT-PW-VC-0130: Expenses: (New Expense Item) 5759.91
- CON-Z3-UT-PW-VC-0910: Expenses: (New Expense Item) 8063.87

| ID | WBS | Activity | Duration | Start | Finish | Predecessors | Total float | Free float | Resources | Cost | Activity Wt% | Weight % | Cost Wt | RPI - PHASE | RPI - CONSTRUCTION | RPI - ZONES | RPI - UTILITY NETWORKS | RPI - TYPE OF WORK | RPI_P2 - BOQ ITEMS | RPI_P2 - CONSTRUCTION | RPI_P2 - PHASE | RPI_P2 - ZONES | RPI_P2 - AREAS | RPI_P2 - DISCIPLINE / WORK TYPE | RPI_P2 - UTILITY NETWORK |
| --- | --- | --- | --- | --- | --- | --- | --- | --- | --- | --- | --- | --- | --- | --- | --- | --- | --- | --- | --- | --- | --- | --- | --- | --- | --- |
|  | 1 | **Washout Chamber at Road A (1st)** |  | 2017-02-25 | 2017-04-09 |  |  |  |  |  |  |  |  |  |  |  |  |  |  |  |  |  |  |  |  |
| CON-Z3-UT-PW-VC-0150 |  | Excavation and Compaction | 1.6d | 2017-02-25 | 2017-02-26 | CON-Z3-UT-PW-PL-0070, CON-Z3-UT-PW-VC-0010 | 30.8d | 0d | Operator - Excavator [20.8 h]; Excavator [22.4 h] | 5,759.91 | 0 | 0 | 0.0030836221 | 6 | RPI - CONS | Z2 | PW | MECH | 1.3.3.20 | CONS | CONS | ZONE-3 | ROAD-A | MECH | PW |
| CON-Z3-UT-PW-VC-0160 |  | Lean concrete | 0.8d | 2017-02-26 | 2017-02-27 | CON-Z3-UT-PW-VC-0150 | 30.8d | 0d | Concrete Mason [52 h]; Driver - Conc. Transit Mixers [26 h]; Operator - Concrete Pump [26 h]; Common Labor / Helper [31.2 h] | 3,455.95 | 0 | 0 | 0.0003088871 | 6 | RPI - CONS | Z2 | PW | MECH | 1.3.3.20 | CONS | CONS | ZONE-3 | ROAD-A | MECH | PW |
| CON-Z3-UT-PW-VC-0170 |  | Formwork for Base Slab | 0.8d | 2017-02-27 | 2017-02-28 | CON-Z3-UT-PW-VC-0160 | 30.8d | 0d | Shuttering Carpenter [78 h]; Common Labor / Helper [52 h] | 5,759.91 | 0 | 0 | 0.000308358 | 6 | RPI - CONS | Z2 | PW | MECH | 1.3.3.20 | CONS | CONS | ZONE-3 | ROAD-A | MECH | PW |
| CON-Z3-UT-PW-VC-0180 |  | Fabrication & installation of Rebar for Base Slab | 4d | 2017-02-28 | 2017-03-05 | CON-Z3-UT-PW-VC-0170 | 30.8d | 0d | Steel Fixer [78 h] | 5,759.91 | 0 | 0 | 0.0015418111 | 6 | RPI - CONS | Z2 | PW | MECH | 1.3.3.20 | CONS | CONS | ZONE-3 | ROAD-A | MECH | PW |
| CON-Z3-UT-PW-VC-0190 |  | Fabrication & installation of Rebar for Side walls | 4d | 2017-03-05 | 2017-03-09 | CON-Z3-UT-PW-VC-0180 | 30.8d | 0d | Steel Fixer [78 h] | 5,759.91 | 0 | 0 | 0.0030836221 | 6 | RPI - CONS | Z2 | PW | MECH | 1.3.3.20 | CONS | CONS | ZONE-3 | ROAD-A | MECH | PW |
| CON-Z3-UT-PW-VC-0200 |  | Formwork for side walls | 4d | 2017-03-06 | 2017-03-09 | CON-Z3-UT-PW-VC-0190 SS+0.8d | 30.8d | 0d | Shuttering Carpenter [78 h]; Common Labor / Helper [26 h]; Scaffolder [52 h] | 5,759.91 | 0 | 0 | 0.0015418111 | 6 | RPI - CONS | Z2 | PW | MECH | 1.3.3.20 | CONS | CONS | ZONE-3 | ROAD-A | MECH | PW |
| CON-Z3-UT-PW-VC-0210 |  | Concrete pouring for base slab | 0.8d | 2017-03-11 | 2017-03-11 | CON-Z3-UT-PW-VC-0200 | 30.8d | 0d | Concrete Mason [20.8 h]; Common Labor / Helper [26 h]; Finishing Work Crew [10.4 h]; Driver - Conc. Transit Mixers [26 h]; Operator - Concrete Pump [26 h] | 11,519.82 | 0 | 0 | 0.0015418111 | 6 | RPI - CONS | Z2 | PW | MECH | 1.3.3.20 | CONS | CONS | ZONE-3 | ROAD-A | MECH | PW |
| CON-Z3-UT-PW-VC-0220 |  | Concrete pouring for Side Wall | 0.8d | 2017-03-11 | 2017-03-12 | CON-Z3-UT-PW-VC-0210 | 30.8d | 0d | Concrete Mason [20.8 h]; Common Labor / Helper [26 h]; Finishing Work Crew [20.8 h]; Driver - Conc. Transit Mixers [26 h]; Operator - Concrete Pump [26 h] | 11,519.82 | 0 | 0 | 0.0040086961 | 6 | RPI - CONS | Z2 | PW | MECH | 1.3.3.20 | CONS | CONS | ZONE-3 | ROAD-A | MECH | PW |
| CON-Z3-UT-PW-VC-0230 |  | Formwork removal and concrete patching | 1.6d | 2017-03-12 | 2017-03-14 | CON-Z3-UT-PW-VC-0220 | 30.8d | 0d | Shuttering Carpenter [78 h]; Scaffolder [26 h]; Finishing Work Crew [52 h] | 2,303.96 | 0 | 0 | 0.0015418111 | 6 | RPI - CONS | Z2 | PW | MECH | 1.3.3.20 | CONS | CONS | ZONE-3 | ROAD-A | MECH | PW |
| CON-Z3-UT-PW-VC-0240 |  | Concrete Supports | 0.8d | 2017-03-14 | 2017-03-14 | CON-Z3-UT-PW-VC-0230 | 30.8d | 0d | Shuttering Carpenter [26 h]; Concrete Mason [26 h]; Common Labor / Helper [26 h] | 17,279.73 | 0 | 0 | 0.000616716 | 6 | RPI - CONS | Z2 | PW | MECH | 1.3.3.20 | CONS | CONS | ZONE-3 | ROAD-A | MECH | PW |
| CON-Z3-UT-PW-VC-0250 |  | Installation of Pipe Connections / Closing of Openings | 3.2d | 2017-03-15 | 2017-03-19 | CON-Z3-UT-PW-VC-0240 | 30.8d | 0d | Shuttering Carpenter [26 h]; Concrete Mason [26 h]; Plumber [160 h]; Common Labor / Helper [26 h] | 3,455.95 | 0 | 0 | 0.0055505071 | 6 | RPI - CONS | Z2 | PW | MECH | 1.3.3.20 | CONS | CONS | ZONE-3 | ROAD-A | MECH | PW |
| CON-Z3-UT-PW-VC-0260 |  | Damp Proof Coating | 0.8d | 2017-03-19 | 2017-03-19 | CON-Z3-UT-PW-VC-0250, CON-Z3-UT-PW-VC-0230 | 30.8d | 0d | Painter [52 h]; Water Proofing Crew [52 h] | 2,303.96 | 0 | 0 | 0.0015418111 | 6 | RPI - CONS | Z2 | PW | MECH | 1.3.3.20 | CONS | CONS | ZONE-3 | ROAD-A | MECH | PW |
| CON-Z3-UT-PW-VC-0270 |  | Backfilling & Compaction | 4d | 2017-03-20 | 2017-03-23 | CON-Z3-UT-PW-VC-0260 | 30.8d | 0d | Common Labor / Helper [52 h]; Driver - Dump Truck [26 h]; Operator - Bobcat [26 h]; Operator - Roller-Compactor (2~10 Ton) [26 h]; Driver - Water Tanker [26 h]; Operator - JCB [26 h]; Bobcat [28 h]; Plate Compactor [28 h]; Vibrators [28 h]; Water Tanker [28 h]; JCB [28 h] | 5,759.91 | 0 | 0 | 0.0037003381 | 6 | RPI - CONS | Z2 | PW | MECH | 1.3.3.20 | CONS | CONS | ZONE-3 | ROAD-A | MECH | PW |
| CON-Z3-UT-PW-VC-0280 |  | Instalaltion of Dismantling Joints | 3d | 2017-03-29 | 2017-04-02 | CON-Z3-UT-PW-VC-0270 FS+4.8d, CON-Z3-UT-PW-VC-0250 SS | 30.8d | 0d | Common Labor / Helper [26 h]; RTR Pipe Crew [26 h] | 5,759.91 | 0 | 0 | 0.002466885 | 6 | RPI - CONS | Z2 | PW | MECH | 1.3.3.20 | CONS | CONS | ZONE-3 | ROAD-A | MECH | PW |
| CON-Z3-UT-PW-VC-0590 |  | Instalaltion of Gate Valves | 2.4d | 2017-04-01 | 2017-04-04 | CON-Z3-UT-PW-VC-0280 SS+2d | 30.8d | 0d | RTR Pipe Crew [62.4 h]; Specialist Works Crew [31.2 h]; Plumber [360 h]; Common Labor / Helper [187.2 h] | 11,519.82 |  |  |  |  |  |  |  |  | 1.3.3.20 | CONS | CONS | ZONE-3 | ROAD-A | MECH | PW |
| CON-Z3-UT-PW-VC-0920 |  | Installation of Roof Slab, Manhole Cover, Accessories & Finishes | 4d | 2017-04-04 | 2017-04-09 | CON-Z3-UT-PW-VC-0910, CON-Z3-UT-PW-VC-0590 | 30.8d | 0d | Common Labor / Helper [156 h]; Finishing Work Crew [156 h]; Plumber [200 h] | 11,519.82 |  |  |  |  |  |  |  |  | 1.3.3.20 | CONS | CONS | ZONE-3 | ROAD-A | MECH | PW |
|  | 3 | **Air Release Valve Chamber at Road 3** |  | 2017-02-26 | 2017-04-10 |  |  |  |  |  |  |  |  |  |  |  |  |  |  |  |  |  |  |  |  |
| CON-Z3-UT-PW-VC-0290 |  | Excavation and Compaction | 1.6d | 2017-02-26 | 2017-02-28 | CON-Z3-UT-PW-VC-0150, CON-Z3-UT-PW-PL-0280 | 33.6d | 0d | Operator - Excavator [20.8 h]; Excavator [22.4 h] | 5,759.91 | 0 | 0 | 0.0030836221 | 6 | RPI - CONS | Z2 | PW | MECH | 1.3.3.20 | CONS | CONS | ZONE-3 | ROAD-3 | MECH | PW |
| CON-Z3-UT-PW-VC-0300 |  | Lean concrete | 0.8d | 2017-02-28 | 2017-02-28 | CON-Z3-UT-PW-VC-0290 | 33.6d | 0d | Concrete Mason [52 h]; Driver - Conc. Transit Mixers [26 h]; Operator - Concrete Pump [26 h] | 3,455.95 | 0 | 0 | 0.0003088871 | 6 | RPI - CONS | Z2 | PW | MECH | 1.3.3.20 | CONS | CONS | ZONE-3 | ROAD-3 | MECH | PW |
| CON-Z3-UT-PW-VC-0310 |  | Formwork for Base Slab | 0.8d | 2017-03-01 | 2017-03-01 | CON-Z3-UT-PW-VC-0300 | 33.6d | 0d | Shuttering Carpenter [78 h]; Common Labor / Helper [52 h] | 5,759.91 | 0 | 0 | 0.000308358 | 6 | RPI - CONS | Z2 | PW | MECH | 1.3.3.20 | CONS | CONS | ZONE-3 | ROAD-3 | MECH | PW |
| CON-Z3-UT-PW-VC-0320 |  | Fabrication & installation of Rebar for Base Slab | 4d | 2017-03-01 | 2017-03-06 | CON-Z3-UT-PW-VC-0310 | 33.6d | 0d | Steel Fixer [78 h] | 5,759.91 | 0 | 0 | 0.0015418111 | 6 | RPI - CONS | Z2 | PW | MECH | 1.3.3.20 | CONS | CONS | ZONE-3 | ROAD-3 | MECH | PW |
| CON-Z3-UT-PW-VC-0330 |  | Fabrication & installation of Rebar for Side walls | 4d | 2017-03-06 | 2017-03-11 | CON-Z3-UT-PW-VC-0320 | 33.6d | 0d | Steel Fixer [78 h] | 5,759.91 | 0 | 0 | 0.0030836221 | 6 | RPI - CONS | Z2 | PW | MECH | 1.3.3.20 | CONS | CONS | ZONE-3 | ROAD-3 | MECH | PW |
| CON-Z3-UT-PW-VC-0340 |  | Formwork for side walls | 4d | 2017-03-07 | 2017-03-12 | CON-Z3-UT-PW-VC-0330 SS+0.8d | 33.6d | 0d | Shuttering Carpenter [78 h]; Common Labor / Helper [26 h]; Scaffolder [52 h] | 5,759.91 | 0 | 0 | 0.0015418111 | 6 | RPI - CONS | Z2 | PW | MECH | 1.3.3.20 | CONS | CONS | ZONE-3 | ROAD-3 | MECH | PW |
| CON-Z3-UT-PW-VC-0350 |  | Concrete pouring for base slab | 0.8d | 2017-03-12 | 2017-03-13 | CON-Z3-UT-PW-VC-0340 | 33.6d | 0d | Concrete Mason [20.8 h]; Common Labor / Helper [26 h]; Finishing Work Crew [10.4 h]; Driver - Conc. Transit Mixers [26 h]; Operator - Concrete Pump [26 h] | 11,519.82 | 0 | 0 | 0.0015418111 | 6 | RPI - CONS | Z2 | PW | MECH | 1.3.3.20 | CONS | CONS | ZONE-3 | ROAD-3 | MECH | PW |
| CON-Z3-UT-PW-VC-0360 |  | Concrete pouring for Side Wall | 0.8d | 2017-03-13 | 2017-03-14 | CON-Z3-UT-PW-VC-0350 | 33.6d | 0d | Concrete Mason [78 h]; Common Labor / Helper [26 h]; Finishing Work Crew [52 h]; Driver - Conc. Transit Mixers [26 h]; Operator - Concrete Pump [26 h] | 11,519.82 | 0 | 0 | 0.0040086961 | 6 | RPI - CONS | Z2 | PW | MECH | 1.3.3.20 | CONS | CONS | ZONE-3 | ROAD-3 | MECH | PW |
| CON-Z3-UT-PW-VC-0370 |  | Formwork removal and concrete patching | 1.6d | 2017-03-14 | 2017-03-15 | CON-Z3-UT-PW-VC-0360 | 33.6d | 0d | Shuttering Carpenter [78 h]; Scaffolder [26 h]; Finishing Work Crew [52 h] | 5,759.91 | 0 | 0 | 0.0015418111 | 6 | RPI - CONS | Z2 | PW | MECH | 1.3.3.20 | CONS | CONS | ZONE-3 | ROAD-3 | MECH | PW |
| CON-Z3-UT-PW-VC-0380 |  | Concrete Supports | 0.8d | 2017-03-15 | 2017-03-16 | CON-Z3-UT-PW-VC-0370 | 33.6d | 0d | Shuttering Carpenter [26 h]; Concrete Mason [26 h]; Common Labor / Helper [26 h] | 17,279.73 | 0 | 0 | 0.000616716 | 6 | RPI - CONS | Z2 | PW | MECH | 1.3.3.20 | CONS | CONS | ZONE-3 | ROAD-3 | MECH | PW |
| CON-Z3-UT-PW-VC-0390 |  | Installation of Valves / Pipe Connections / Closing of Openings | 3.2d | 2017-03-16 | 2017-03-20 | CON-Z3-UT-PW-VC-0380 | 33.6d | 0d | Shuttering Carpenter [26 h]; Concrete Mason [26 h]; Common Labor / Helper [26 h]; RTR Pipe Crew [160 h] | 17,279.73 | 0 | 0 | 0.0055505071 | 6 | RPI - CONS | Z2 | PW | MECH | 1.3.3.20 | CONS | CONS | ZONE-3 | ROAD-3 | MECH | PW |
| CON-Z3-UT-PW-VC-0400 |  | Damp Proof Coating | 0.8d | 2017-03-20 | 2017-03-21 | CON-Z3-UT-PW-VC-0370, CON-Z3-UT-PW-VC-0390 | 33.6d | 0d | Painter [52 h]; Water Proofing Crew [52 h] | 2,303.96 | 0 | 0 | 0.0015418111 | 6 | RPI - CONS | Z2 | PW | MECH | 1.3.3.20 | CONS | CONS | ZONE-3 | ROAD-3 | MECH | PW |
| CON-Z3-UT-PW-VC-0410 |  | Backfilling & Compaction | 4d | 2017-03-21 | 2017-03-26 | CON-Z3-UT-PW-VC-0400 | 33.6d | 2.8d | Common Labor / Helper [52 h]; Driver - Dump Truck [26 h]; Operator - Bobcat [26 h]; Operator - Roller-Compactor (2~10 Ton) [26 h]; Driver - Water Tanker [26 h]; Operator - JCB [26 h]; Bobcat [28 h]; Plate Compactor [28 h]; Vibrators [28 h]; Water Tanker [28 h]; JCB [28 h] | 5,759.91 | 0 | 0 | 0.0037003381 | 6 | RPI - CONS | Z2 | PW | MECH | 1.3.3.20 | CONS | CONS | ZONE-3 | ROAD-3 | MECH | PW |
| CON-Z3-UT-PW-VC-0420 |  | Installation of Roof Slab, Manhole Cover, Accessories & Finishes | 5.6d | 2017-04-04 | 2017-04-10 | CON-Z3-UT-PW-VC-0280, CON-Z3-UT-PW-VC-0410 FS+4.8d, CON-Z3-UT-PW-VC-0280 FF, CON-Z3-UT-PW-VC-0920 SS | 30.8d | 0d | Common Labor / Helper [218.4 h]; Finishing Work Crew [218.4 h]; Plumber [336 h] | 11,519.82 | 0 | 0 | 0.002466885 | 6 | RPI - CONS | Z2 | PW | MECH | 1.3.3.20 | CONS | CONS | ZONE-3 | ROAD-3 | MECH | PW |

Notes:
- CON-Z3-UT-PW-VC-0150: Expenses: (New Expense Item) 5759.91
- CON-Z3-UT-PW-VC-0160: Expenses: (New Expense Item) 3455.95
- CON-Z3-UT-PW-VC-0170: Expenses: (New Expense Item) 5759.91
- CON-Z3-UT-PW-VC-0180: Expenses: (New Expense Item) 5759.91
- CON-Z3-UT-PW-VC-0190: Expenses: (New Expense Item) 5759.91
- CON-Z3-UT-PW-VC-0200: Expenses: (New Expense Item) 5759.91
- CON-Z3-UT-PW-VC-0210: Expenses: (New Expense Item) 11519.8
- CON-Z3-UT-PW-VC-0220: Expenses: (New Expense Item) 11519.8
- CON-Z3-UT-PW-VC-0230: Expenses: (New Expense Item) 2303.96
- CON-Z3-UT-PW-VC-0240: Expenses: (New Expense Item) 17279.7
- CON-Z3-UT-PW-VC-0250: Expenses: (New Expense Item) 3455.95
- CON-Z3-UT-PW-VC-0260: Expenses: (New Expense Item) 2303.96
- CON-Z3-UT-PW-VC-0270: Expenses: (New Expense Item) 5759.91
- CON-Z3-UT-PW-VC-0280: Expenses: (New Expense Item) 5759.91
- CON-Z3-UT-PW-VC-0590: Expenses: (New Expense Item) 11519.8
- CON-Z3-UT-PW-VC-0920: Expenses: (New Expense Item) 11519.8
- CON-Z3-UT-PW-VC-0290: Expenses: (New Expense Item) 5759.91
- CON-Z3-UT-PW-VC-0300: Expenses: (New Expense Item) 3455.95
- CON-Z3-UT-PW-VC-0310: Expenses: (New Expense Item) 5759.91
- CON-Z3-UT-PW-VC-0320: Expenses: (New Expense Item) 5759.91
- CON-Z3-UT-PW-VC-0330: Expenses: (New Expense Item) 5759.91
- CON-Z3-UT-PW-VC-0340: Expenses: (New Expense Item) 5759.91
- CON-Z3-UT-PW-VC-0350: Expenses: (New Expense Item) 11519.8
- CON-Z3-UT-PW-VC-0360: Expenses: (New Expense Item) 11519.8
- CON-Z3-UT-PW-VC-0370: Expenses: (New Expense Item) 5759.91
- CON-Z3-UT-PW-VC-0380: Expenses: (New Expense Item) 17279.7
- CON-Z3-UT-PW-VC-0390: Expenses: (New Expense Item) 17279.7
- CON-Z3-UT-PW-VC-0400: Expenses: (New Expense Item) 2303.96
- CON-Z3-UT-PW-VC-0410: Expenses: (New Expense Item) 5759.91
- CON-Z3-UT-PW-VC-0420: Expenses: (New Expense Item) 11519.8

| ID | WBS | Activity | Duration | Start | Finish | Predecessors | Total float | Free float | Resources | Cost | Activity Wt% | Weight % | Cost Wt | RPI - PHASE | RPI - CONSTRUCTION | RPI - ZONES | RPI - UTILITY NETWORKS | RPI - TYPE OF WORK | RPI_P2 - BOQ ITEMS | RPI_P2 - CONSTRUCTION | RPI_P2 - PHASE | RPI_P2 - ZONES | RPI_P2 - AREAS | RPI_P2 - DISCIPLINE / WORK TYPE | RPI_P2 - UTILITY NETWORK |
| --- | --- | --- | --- | --- | --- | --- | --- | --- | --- | --- | --- | --- | --- | --- | --- | --- | --- | --- | --- | --- | --- | --- | --- | --- | --- |
|  | 4 | **Washout Chamber at Road 3** |  | 2017-02-28 | 2017-04-17 |  |  |  |  |  |  |  |  |  |  |  |  |  |  |  |  |  |  |  |  |
| CON-Z3-UT-PW-VC-0430 |  | Excavation and Compaction | 1.6d | 2017-02-28 | 2017-03-01 | CON-Z3-UT-PW-PL-0280, CON-Z3-UT-PW-VC-0290 | 34.6d | 0d | Operator - Excavator [26 h] | 5,759.91 | 0 | 0 | 0.0030836221 | 6 | RPI - CONS | Z2 | PW | MECH | 1.3.3.20 | CONS | CONS | ZONE-3 | ROAD-3 | MECH | PW |
| CON-Z3-UT-PW-VC-0440 |  | Lean concrete | 0.8d | 2017-03-01 | 2017-03-02 | CON-Z3-UT-PW-VC-0430 | 34.6d | 0d | Concrete Mason [52 h]; Driver - Conc. Transit Mixers [26 h]; Operator - Concrete Pump [26 h] | 3,455.95 | 0 | 0 | 0.0003088871 | 6 | RPI - CONS | Z2 | PW | MECH | 1.3.3.20 | CONS | CONS | ZONE-3 | ROAD-3 | MECH | PW |
| CON-Z3-UT-PW-VC-0450 |  | Formwork for Base Slab | 0.8d | 2017-03-02 | 2017-03-04 | CON-Z3-UT-PW-VC-0440 | 34.6d | 0d | Shuttering Carpenter [78 h]; Common Labor / Helper [52 h] | 5,759.91 | 0 | 0 | 0.000308358 | 6 | RPI - CONS | Z2 | PW | MECH | 1.3.3.20 | CONS | CONS | ZONE-3 | ROAD-3 | MECH | PW |
| CON-Z3-UT-PW-VC-0460 |  | Fabrication & installation of Rebar for Base Slab | 4d | 2017-03-04 | 2017-03-08 | CON-Z3-UT-PW-VC-0450 | 34.6d | 0d | Steel Fixer [78 h] | 5,759.91 | 0 | 0 | 0.0015418111 | 6 | RPI - CONS | Z2 | PW | MECH | 1.3.3.20 | CONS | CONS | ZONE-3 | ROAD-3 | MECH | PW |
| CON-Z3-UT-PW-VC-0470 |  | Fabrication & installation of Rebar for Side walls | 4d | 2017-03-08 | 2017-03-13 | CON-Z3-UT-PW-VC-0460 | 34.6d | 0d | Steel Fixer [78 h] | 5,759.91 | 0 | 0 | 0.0030836221 | 6 | RPI - CONS | Z2 | PW | MECH | 1.3.3.20 | CONS | CONS | ZONE-3 | ROAD-3 | MECH | PW |
| CON-Z3-UT-PW-VC-0480 |  | Formwork for side walls | 4d | 2017-03-09 | 2017-03-14 | CON-Z3-UT-PW-VC-0470 SS+0.8d | 34.6d | 0d | Shuttering Carpenter [78 h]; Common Labor / Helper [26 h]; Scaffolder [52 h] | 5,759.91 | 0 | 0 | 0.0015418111 | 6 | RPI - CONS | Z2 | PW | MECH | 1.3.3.20 | CONS | CONS | ZONE-3 | ROAD-3 | MECH | PW |
| CON-Z3-UT-PW-VC-0490 |  | Concrete pouring for base slab | 0.8d | 2017-03-14 | 2017-03-14 | CON-Z3-UT-PW-VC-0480 | 34.6d | 0d | Concrete Mason [20.8 h]; Common Labor / Helper [26 h]; Finishing Work Crew [10.4 h]; Driver - Conc. Transit Mixers [26 h]; Operator - Concrete Pump [26 h] | 11,519.82 | 0 | 0 | 0.0015418111 | 6 | RPI - CONS | Z2 | PW | MECH | 1.3.3.20 | CONS | CONS | ZONE-3 | ROAD-3 | MECH | PW |
| CON-Z3-UT-PW-VC-0500 |  | Concrete pouring for Side Wall | 0.8d | 2017-03-15 | 2017-03-15 | CON-Z3-UT-PW-VC-0490 | 34.6d | 0d | Concrete Mason [20.8 h]; Common Labor / Helper [26 h]; Finishing Work Crew [10.4 h]; Driver - Conc. Transit Mixers [26 h]; Operator - Concrete Pump [26 h] | 11,519.82 | 0 | 0 | 0.0040086961 | 6 | RPI - CONS | Z2 | PW | MECH | 1.3.3.20 | CONS | CONS | ZONE-3 | ROAD-3 | MECH | PW |
| CON-Z3-UT-PW-VC-0510 |  | Formwork removal and concrete patching | 1.6d | 2017-03-15 | 2017-03-18 | CON-Z3-UT-PW-VC-0500 | 34.6d | 0d | Shuttering Carpenter [41.6 h]; Scaffolder [26 h]; Finishing Work Crew [52 h] | 2,303.96 | 0 | 0 | 0.0015418111 | 6 | RPI - CONS | Z2 | PW | MECH | 1.3.3.20 | CONS | CONS | ZONE-3 | ROAD-3 | MECH | PW |
| CON-Z3-UT-PW-VC-0520 |  | Concrete Supports | 0.8d | 2017-03-18 | 2017-03-19 | CON-Z3-UT-PW-VC-0510 | 34.6d | 0d | Shuttering Carpenter [26 h]; Concrete Mason [26 h]; Common Labor / Helper [26 h] | 17,279.73 | 0 | 0 | 0.000616716 | 6 | RPI - CONS | Z2 | PW | MECH | 1.3.3.20 | CONS | CONS | ZONE-3 | ROAD-3 | MECH | PW |
| CON-Z3-UT-PW-VC-0530 |  | Installation of Pipe Connections / Closing of Openings | 3.2d | 2017-03-19 | 2017-03-22 | CON-Z3-UT-PW-VC-0520 | 34.6d | 0d | Shuttering Carpenter [26 h]; Concrete Mason [26 h]; Plumber [160 h]; Common Labor / Helper [26 h] | 3,455.95 | 0 | 0 | 0.0055505071 | 6 | RPI - CONS | Z2 | PW | MECH | 1.3.3.20 | CONS | CONS | ZONE-3 | ROAD-3 | MECH | PW |
| CON-Z3-UT-PW-VC-0540 |  | Damp Proof Coating | 0.8d | 2017-03-22 | 2017-03-23 | CON-Z3-UT-PW-VC-0510, CON-Z3-UT-PW-VC-0530 | 34.6d | 0d | Painter [20.8 h]; Water Proofing Crew [20.8 h] | 2,303.96 | 0 | 0 | 0.0015418111 | 6 | RPI - CONS | Z2 | PW | MECH | 1.3.3.20 | CONS | CONS | ZONE-3 | ROAD-3 | MECH | PW |
| CON-Z3-UT-PW-VC-0550 |  | Backfilling & Compaction | 4d | 2017-03-23 | 2017-03-28 | CON-Z3-UT-PW-VC-0540 | 34.6d | 3.8d | Common Labor / Helper [52 h]; Driver - Dump Truck [26 h]; Operator - Bobcat [26 h]; Operator - Roller-Compactor (2~10 Ton) [26 h]; Driver - Water Tanker [26 h]; Operator - JCB [26 h]; Bobcat [28 h]; Plate Compactor [28 h]; Vibrators [28 h]; Water Tanker [28 h]; JCB [28 h] | 5,759.91 | 0 | 0 | 0.0037003381 | 6 | RPI - CONS | Z2 | PW | MECH | 1.3.3.20 | CONS | CONS | ZONE-3 | ROAD-3 | MECH | PW |
| CON-Z3-UT-PW-VC-0600 |  | Instalaltion of Dismantling Joints | 3d | 2017-04-06 | 2017-04-10 | CON-Z3-UT-PW-VC-0420 FF, CON-Z3-UT-PW-VC-0550 FS+4.8d, CON-Z3-UT-PW-VC-0530 SS | 30.8d | 0d | Common Labor / Helper [156 h]; RTR Pipe Crew [60 h]; Plumber [150 h] | 5,759.91 | 0 | 0 | 0.002466885 | 6 | RPI - CONS | Z2 | PW | MECH | 1.3.3.20 | CONS | CONS | ZONE-3 | ROAD-3 | MECH | PW |
| CON-Z3-UT-PW-VC-0930 |  | Instalaltion of Gate Valves | 2.4d | 2017-04-09 | 2017-04-12 | CON-Z3-UT-PW-VC-0600 SS+2d | 32.2d | 0d | Common Labor / Helper [124.8 h]; RTR Pipe Crew [62.4 h]; Specialist Works Crew [31.2 h] | 13,823.78 |  |  |  |  |  |  |  |  | 1.3.3.20 | CONS | CONS | ZONE-3 | ROAD-3 | MECH | PW |
| CON-Z3-UT-PW-VC-0940 |  | Installation of Roof Slab, Manhole Cover, Accessories & Finishes | 4d | 2017-04-12 | 2017-04-17 | CON-Z3-UT-PW-VC-0420 SS, CON-Z3-UT-PW-VC-0930 | 32.2d | 0d | Common Labor / Helper [260 h]; Finishing Work Crew [52 h] | 9,215.85 |  |  |  |  |  |  |  |  | 1.3.3.20 | CONS | CONS | ZONE-3 | ROAD-3 | MECH | PW |
|  | 5 | **Chamber - VB Type D at Road 4 (1st)** |  | 2017-03-01 | 2017-04-22 |  |  |  |  |  |  |  |  |  |  |  |  |  |  |  |  |  |  |  |  |
| CON-Z3-UT-PW-VC-0610 |  | Excavation and Compaction | 1.6d | 2017-03-01 | 2017-03-04 | CON-Z3-UT-PW-VC-0430, CON-Z3-UT-PW-PL-0370 | 36d | 0d | Operator - Excavator [26 h] | 5,759.91 | 0 | 0 | 0.0030836221 | 6 | RPI - CONS | Z2 | PW | MECH | 1.3.3.20 | CONS | CONS | ZONE-3 | ROAD-4 | MECH | PW |
| CON-Z3-UT-PW-VC-0620 |  | Lean concrete | 0.8d | 2017-03-04 | 2017-03-05 | CON-Z3-UT-PW-VC-0610 | 36d | 0d | Operator - Excavator [26 h] | 3,455.95 | 0 | 0 | 0.0003088871 | 6 | RPI - CONS | Z2 | PW | MECH | 1.3.3.20 | CONS | CONS | ZONE-3 | ROAD-4 | MECH | PW |
| CON-Z3-UT-PW-VC-0630 |  | Formwork for Base Slab | 0.8d | 2017-03-05 | 2017-03-05 | CON-Z3-UT-PW-VC-0620 | 36d | 0d | Shuttering Carpenter [78 h]; Common Labor / Helper [52 h] | 5,759.91 | 0 | 0 | 0.000308358 | 6 | RPI - CONS | Z2 | PW | MECH | 1.3.3.20 | CONS | CONS | ZONE-3 | ROAD-4 | MECH | PW |
| CON-Z3-UT-PW-VC-0640 |  | Fabrication & installation of Rebar for Base Slab | 4d | 2017-03-06 | 2017-03-09 | CON-Z3-UT-PW-VC-0630 | 36d | 0d | Steel Fixer [78 h] | 5,759.91 | 0 | 0 | 0.0015418111 | 6 | RPI - CONS | Z2 | PW | MECH | 1.3.3.20 | CONS | CONS | ZONE-3 | ROAD-4 | MECH | PW |
| CON-Z3-UT-PW-VC-0650 |  | Fabrication & installation of Rebar for Side walls | 4d | 2017-03-11 | 2017-03-14 | CON-Z3-UT-PW-VC-0640 | 36d | 0d | Steel Fixer [78 h] | 5,759.91 | 0 | 0 | 0.0030836221 | 6 | RPI - CONS | Z2 | PW | MECH | 1.3.3.20 | CONS | CONS | ZONE-3 | ROAD-4 | MECH | PW |
| CON-Z3-UT-PW-VC-0660 |  | Formwork for side walls | 4d | 2017-03-11 | 2017-03-15 | CON-Z3-UT-PW-VC-0650 SS+0.8d | 36d | 0d | Shuttering Carpenter [78 h]; Common Labor / Helper [26 h]; Scaffolder [52 h] | 5,759.91 | 0 | 0 | 0.0015418111 | 6 | RPI - CONS | Z2 | PW | MECH | 1.3.3.20 | CONS | CONS | ZONE-3 | ROAD-4 | MECH | PW |
| CON-Z3-UT-PW-VC-0670 |  | Concrete pouring for base slab | 0.8d | 2017-03-15 | 2017-03-16 | CON-Z3-UT-PW-VC-0660 | 36d | 0d | Concrete Mason [20.8 h]; Common Labor / Helper [26 h]; Finishing Work Crew [10.4 h]; Driver - Conc. Transit Mixers [26 h]; Operator - Concrete Pump [26 h] | 11,519.82 | 0 | 0 | 0.0015418111 | 6 | RPI - CONS | Z2 | PW | MECH | 1.3.3.20 | CONS | CONS | ZONE-3 | ROAD-4 | MECH | PW |
| CON-Z3-UT-PW-VC-0680 |  | Concrete pouring for Side Wall | 0.8d | 2017-03-16 | 2017-03-18 | CON-Z3-UT-PW-VC-0670 | 36d | 0d | Concrete Mason [78 h]; Common Labor / Helper [26 h]; Finishing Work Crew [52 h]; Driver - Conc. Transit Mixers [26 h]; Operator - Concrete Pump [26 h] | 11,519.82 | 0 | 0 | 0.0040086961 | 6 | RPI - CONS | Z2 | PW | MECH | 1.3.3.20 | CONS | CONS | ZONE-3 | ROAD-4 | MECH | PW |
| CON-Z3-UT-PW-VC-0690 |  | Formwork removal and concrete patching | 1.6d | 2017-03-18 | 2017-03-19 | CON-Z3-UT-PW-VC-0680 | 36d | 0d | Shuttering Carpenter [41.6 h]; Scaffolder [26 h]; Finishing Work Crew [52 h] | 2,303.96 | 0 | 0 | 0.0015418111 | 6 | RPI - CONS | Z2 | PW | MECH | 1.3.3.20 | CONS | CONS | ZONE-3 | ROAD-4 | MECH | PW |
| CON-Z3-UT-PW-VC-0700 |  | Concrete Supports | 0.8d | 2017-03-20 | 2017-03-20 | CON-Z3-UT-PW-VC-0690 | 36d | 0d | Shuttering Carpenter [26 h]; Concrete Mason [26 h]; Common Labor / Helper [26 h] | 17,279.73 | 0 | 0 | 0.000616716 | 6 | RPI - CONS | Z2 | PW | MECH | 1.3.3.20 | CONS | CONS | ZONE-3 | ROAD-4 | MECH | PW |
| CON-Z3-UT-PW-VC-0710 |  | Installation of Pipe Connections / Closing of Openings | 3.2d | 2017-03-20 | 2017-03-23 | CON-Z3-UT-PW-VC-0700 | 36d | 0d | Shuttering Carpenter [26 h]; Concrete Mason [26 h]; Plumber [160 h]; Common Labor / Helper [26 h] | 3,455.95 | 0 | 0 | 0.0055505071 | 6 | RPI - CONS | Z2 | PW | MECH | 1.3.3.20 | CONS | CONS | ZONE-3 | ROAD-4 | MECH | PW |
| CON-Z3-UT-PW-VC-0720 |  | Damp Proof Coating | 0.8d | 2017-03-25 | 2017-03-25 | CON-Z3-UT-PW-VC-0710, CON-Z3-UT-PW-VC-0690 | 36d | 0d | Painter [20.8 h]; Water Proofing Crew [20.8 h] | 2,303.96 | 0 | 0 | 0.0015418111 | 6 | RPI - CONS | Z2 | PW | MECH | 1.3.3.20 | CONS | CONS | ZONE-3 | ROAD-4 | MECH | PW |
| CON-Z3-UT-PW-VC-0730 |  | Backfilling & Compaction | 4d | 2017-03-25 | 2017-03-29 | CON-Z3-UT-PW-VC-0720 | 36d | 5.2d | Operator - JCB [26 h]; Bobcat [28 h]; Plate Compactor [28 h]; Vibrators [28 h]; Water Tanker [28 h]; JCB [28 h]; Common Labor / Helper [52 h]; Driver - Dump Truck [26 h]; Operator - Bobcat [26 h]; Operator - Roller-Compactor (2~10 Ton) [26 h]; Driver - Water Tanker [26 h] | 5,759.91 | 0 | 0 | 0.0037003381 | 6 | RPI - CONS | Z2 | PW | MECH | 1.3.3.20 | CONS | CONS | ZONE-3 | ROAD-4 | MECH | PW |
| CON-Z3-UT-PW-VC-0740 |  | Instalaltion of Dismantling Joints | 3d | 2017-04-10 | 2017-04-13 | CON-Z3-UT-PW-VC-0600 FF, CON-Z3-UT-PW-VC-0730 FS+4.8d, CON-Z3-UT-PW-VC-0710 SS, CON-Z3-UT-PW-VC-0600 | 30.8d | 0d | Common Labor / Helper [156 h]; RTR Pipe Crew [120 h]; Plumber [240 h] | 5,759.91 | 0 | 0 | 0.002466885 | 6 | RPI - CONS | Z2 | PW | MECH | 1.3.3.20 | CONS | CONS | ZONE-3 | ROAD-4 | MECH | PW |
| CON-Z3-UT-PW-VC-0950 |  | Instalaltion of Gate Valves and Pressure Releasing Valves | 2.4d | 2017-04-12 | 2017-04-16 | CON-Z3-UT-PW-VC-0740 SS+2d | 33.2d | 1d | Common Labor / Helper [124.8 h]; RTR Pipe Crew [96 h]; Plumber [144 h] | 13,823.78 |  |  |  |  |  |  |  |  | 1.3.3.20 | CONS | CONS | ZONE-3 | ROAD-4 | MECH | PW |
| CON-Z3-UT-PW-VC-0960 |  | Installation of Roof Slab, Manhole Cover, Accessories & Finishes | 4d | 2017-04-17 | 2017-04-22 | CON-Z3-UT-PW-VC-0950, CON-Z3-UT-PW-VC-0940 | 32.2d | 1.4d | Common Labor / Helper [260 h]; Finishing Work Crew [240 h] | 9,215.85 |  |  |  |  |  |  |  |  | 1.3.3.20 | CONS | CONS | ZONE-3 | ROAD-4 | MECH | PW |

Notes:
- CON-Z3-UT-PW-VC-0430: Expenses: (New Expense Item) 5759.91
- CON-Z3-UT-PW-VC-0440: Expenses: (New Expense Item) 3455.95
- CON-Z3-UT-PW-VC-0450: Expenses: (New Expense Item) 5759.91
- CON-Z3-UT-PW-VC-0460: Expenses: (New Expense Item) 5759.91
- CON-Z3-UT-PW-VC-0470: Expenses: (New Expense Item) 5759.91
- CON-Z3-UT-PW-VC-0480: Expenses: (New Expense Item) 5759.91
- CON-Z3-UT-PW-VC-0490: Expenses: (New Expense Item) 11519.8
- CON-Z3-UT-PW-VC-0500: Expenses: (New Expense Item) 11519.8
- CON-Z3-UT-PW-VC-0510: Expenses: (New Expense Item) 2303.96
- CON-Z3-UT-PW-VC-0520: Expenses: (New Expense Item) 17279.7
- CON-Z3-UT-PW-VC-0530: Expenses: (New Expense Item) 3455.95
- CON-Z3-UT-PW-VC-0540: Expenses: (New Expense Item) 2303.96
- CON-Z3-UT-PW-VC-0550: Expenses: (New Expense Item) 5759.91
- CON-Z3-UT-PW-VC-0600: Expenses: (New Expense Item) 5759.91
- CON-Z3-UT-PW-VC-0930: Expenses: (New Expense Item) 13823.8
- CON-Z3-UT-PW-VC-0940: Expenses: (New Expense Item) 9215.85
- CON-Z3-UT-PW-VC-0610: Expenses: (New Expense Item) 5759.91
- CON-Z3-UT-PW-VC-0620: Expenses: (New Expense Item) 3455.95
- CON-Z3-UT-PW-VC-0630: Expenses: (New Expense Item) 5759.91
- CON-Z3-UT-PW-VC-0640: Expenses: (New Expense Item) 5759.91
- CON-Z3-UT-PW-VC-0650: Expenses: (New Expense Item) 5759.91
- CON-Z3-UT-PW-VC-0660: Expenses: (New Expense Item) 5759.91
- CON-Z3-UT-PW-VC-0670: Expenses: (New Expense Item) 11519.8
- CON-Z3-UT-PW-VC-0680: Expenses: (New Expense Item) 11519.8
- CON-Z3-UT-PW-VC-0690: Expenses: (New Expense Item) 2303.96
- CON-Z3-UT-PW-VC-0700: Expenses: (New Expense Item) 17279.7
- CON-Z3-UT-PW-VC-0710: Expenses: (New Expense Item) 3455.95
- CON-Z3-UT-PW-VC-0720: Expenses: (New Expense Item) 2303.96
- CON-Z3-UT-PW-VC-0730: Expenses: (New Expense Item) 5759.91
- CON-Z3-UT-PW-VC-0740: Expenses: (New Expense Item) 5759.91
- CON-Z3-UT-PW-VC-0950: Expenses: (New Expense Item) 13823.8
- CON-Z3-UT-PW-VC-0960: Expenses: (New Expense Item) 9215.85

| ID | WBS | Activity | Duration | Start | Finish | Predecessors | Total float | Free float | Resources | Cost | Activity Wt% | Weight % | Cost Wt | RPI - PHASE | RPI - CONSTRUCTION | RPI - ZONES | RPI - UTILITY NETWORKS | RPI - TYPE OF WORK | RPI_P2 - BOQ ITEMS | RPI_P2 - CONSTRUCTION | RPI_P2 - PHASE | RPI_P2 - ZONES | RPI_P2 - AREAS | RPI_P2 - DISCIPLINE / WORK TYPE | RPI_P2 - UTILITY NETWORK |
| --- | --- | --- | --- | --- | --- | --- | --- | --- | --- | --- | --- | --- | --- | --- | --- | --- | --- | --- | --- | --- | --- | --- | --- | --- | --- |
|  | 6 | **Chamber - VB Type D at Road 4 (2nd)** |  | 2017-03-04 | 2017-04-30 |  |  |  |  |  |  |  |  |  |  |  |  |  |  |  |  |  |  |  |  |
| CON-Z3-UT-PW-VC-0750 |  | Excavation and Compaction | 1.6d | 2017-03-04 | 2017-03-05 | CON-Z3-UT-PW-VC-0610 | 46.2d | 0d | Operator - Excavator [26 h] | 5,759.91 | 0 | 0 | 0.0030836221 | 6 | RPI - CONS | Z2 | PW | MECH | 1.3.3.20 | CONS | CONS | ZONE-3 | ROAD-4 | MECH | PW |
| CON-Z3-UT-PW-VC-0760 |  | Lean concrete | 0.8d | 2017-03-06 | 2017-03-06 | CON-Z3-UT-PW-VC-0750 | 46.2d | 0d | Concrete Mason [52 h]; Driver - Conc. Transit Mixers [26 h]; Operator - Concrete Pump [26 h] | 3,455.95 | 0 | 0 | 0.0003088871 | 6 | RPI - CONS | Z2 | PW | MECH | 1.3.3.20 | CONS | CONS | ZONE-3 | ROAD-4 | MECH | PW |
| CON-Z3-UT-PW-VC-0780 |  | Formwork for Base Slab | 0.8d | 2017-03-06 | 2017-03-07 | CON-Z3-UT-PW-VC-0760 | 46.2d | 0d | Shuttering Carpenter [78 h]; Common Labor / Helper [52 h] | 5,759.91 | 0 | 0 | 0.000308358 | 6 | RPI - CONS | Z2 | PW | MECH | 1.3.3.20 | CONS | CONS | ZONE-3 | ROAD-4 | MECH | PW |
| CON-Z3-UT-PW-VC-0770 |  | Fabrication & installation of Rebar for Base Slab | 4d | 2017-03-07 | 2017-03-12 | CON-Z3-UT-PW-VC-0780 | 46.2d | 0d | Steel Fixer [78 h] | 5,759.91 | 0 | 0 | 0.0015418111 | 6 | RPI - CONS | Z2 | PW | MECH | 1.3.3.20 | CONS | CONS | ZONE-3 | ROAD-4 | MECH | PW |
| CON-Z3-UT-PW-VC-0800 |  | Fabrication & installation of Rebar for Side walls | 4d | 2017-03-12 | 2017-03-16 | CON-Z3-UT-PW-VC-0770 | 46.2d | 0d | Steel Fixer [78 h] | 5,759.91 | 0 | 0 | 0.0030836221 | 6 | RPI - CONS | Z2 | PW | MECH | 1.3.3.20 | CONS | CONS | ZONE-3 | ROAD-4 | MECH | PW |
| CON-Z3-UT-PW-VC-0810 |  | Formwork for side walls | 4d | 2017-03-13 | 2017-03-18 | CON-Z3-UT-PW-VC-0800 SS+0.8d | 46.2d | 0d | Shuttering Carpenter [78 h]; Common Labor / Helper [26 h]; Scaffolder [52 h] | 11,519.82 | 0 | 0 | 0.0015418111 | 6 | RPI - CONS | Z2 | PW | MECH | 1.3.3.20 | CONS | CONS | ZONE-3 | ROAD-4 | MECH | PW |
| CON-Z3-UT-PW-VC-0790 |  | Concrete pouring for base slab | 0.8d | 2017-03-18 | 2017-03-19 | CON-Z3-UT-PW-VC-0810 | 46.2d | 0d | Concrete Mason [78 h]; Common Labor / Helper [26 h]; Finishing Work Crew [52 h]; Driver - Conc. Transit Mixers [26 h]; Operator - Concrete Pump [26 h] | 5,759.91 | 0 | 0 | 0.0015418111 | 6 | RPI - CONS | Z2 | PW | MECH | 1.3.3.20 | CONS | CONS | ZONE-3 | ROAD-4 | MECH | PW |
| CON-Z3-UT-PW-VC-0820 |  | Concrete pouring for Side Wall | 0.8d | 2017-03-19 | 2017-03-19 | CON-Z3-UT-PW-VC-0790 | 46.2d | 0d | Concrete Mason [78 h]; Common Labor / Helper [26 h]; Finishing Work Crew [52 h]; Driver - Conc. Transit Mixers [26 h]; Operator - Concrete Pump [26 h] | 11,519.82 | 0 | 0 | 0.0040086961 | 6 | RPI - CONS | Z2 | PW | MECH | 1.3.3.20 | CONS | CONS | ZONE-3 | ROAD-4 | MECH | PW |
| CON-Z3-UT-PW-VC-0830 |  | Formwork removal and concrete patching | 1.6d | 2017-03-20 | 2017-03-21 | CON-Z3-UT-PW-VC-0820 | 46.2d | 0d | Shuttering Carpenter [78 h]; Scaffolder [26 h]; Finishing Work Crew [52 h] | 2,303.96 | 0 | 0 | 0.0015418111 | 6 | RPI - CONS | Z2 | PW | MECH | 1.3.3.20 | CONS | CONS | ZONE-3 | ROAD-4 | MECH | PW |
| CON-Z3-UT-PW-VC-0850 |  | Concrete Supports | 0.8d | 2017-03-21 | 2017-03-22 | CON-Z3-UT-PW-VC-0830 | 46.2d | 0d | Shuttering Carpenter [26 h]; Concrete Mason [26 h]; Common Labor / Helper [26 h] | 3,455.95 | 0 | 0 | 0.000616716 | 6 | RPI - CONS | Z2 | PW | MECH | 1.3.3.20 | CONS | CONS | ZONE-3 | ROAD-4 | MECH | PW |
| CON-Z3-UT-PW-VC-0860 |  | Installation of Pipe Connections / Closing of Openings | 3.2d | 2017-03-22 | 2017-03-26 | CON-Z3-UT-PW-VC-0850 | 46.2d | 0d | Shuttering Carpenter [26 h]; Concrete Mason [26 h]; Plumber [26 h]; Common Labor / Helper [26 h] | 2,303.96 | 0 | 0 | 0.0055505071 | 6 | RPI - CONS | Z2 | PW | MECH | 1.3.3.20 | CONS | CONS | ZONE-3 | ROAD-4 | MECH | PW |
| CON-Z3-UT-PW-VC-0840 |  | Damp Proof Coating | 0.8d | 2017-03-26 | 2017-03-27 | CON-Z3-UT-PW-VC-0860, CON-Z3-UT-PW-VC-0830 | 46.2d | 15.4d | Painter [20.8 h]; Water Proofing Crew [20.8 h] | 17,279.73 | 0 | 0 | 0.0015418111 | 6 | RPI - CONS | Z2 | PW | MECH | 1.3.3.20 | CONS | CONS | ZONE-3 | ROAD-4 | MECH | PW |
| CON-Z3-UT-PW-VC-0880 |  | Instalaltion of Dismantling Joints | 3d | 2017-04-13 | 2017-04-17 | CON-Z3-UT-PW-VC-0860 SS, CON-Z3-UT-PW-VC-0840, CON-Z3-UT-PW-VC-0740 | 30.8d | 0d | Common Labor / Helper [195 h]; RTR Pipe Crew [120 h] | 5,759.91 | 0 | 0 | 0.0037003381 | 6 | RPI - CONS | Z2 | PW | MECH | 1.3.3.20 | CONS | CONS | ZONE-3 | ROAD-4 | MECH | PW |
| CON-Z3-UT-PW-VC-0970 |  | Instalaltion of Gate Valves and Pressure Releasing Valves | 2.4d | 2017-04-16 | 2017-04-19 | CON-Z3-UT-PW-VC-0880 SS+2d | 34.2d | 3.4d | Common Labor / Helper [156 h]; RTR Pipe Crew [72 h] | 13,823.78 |  |  |  |  |  |  |  |  | 1.3.3.20 | CONS | CONS | ZONE-3 | ROAD-4 | MECH | PW |
| CON-Z3-UT-PW-VC-0870 |  | Backfilling & Compaction | 5.6d | 2017-04-23 | 2017-04-30 | CON-Z3-UT-PW-VC-0880 FS+4.8d | 30.8d | 0d | Common Labor / Helper [364 h]; Driver - Dump Truck [72.8 h]; Operator - Bobcat [72.8 h]; Operator - Roller-Compactor (2~10 Ton) [72.8 h]; Driver - Water Tanker [72.8 h]; Operator - JCB [72.8 h]; Bobcat [78.4 h]; Plate Compactor [78.4 h]; Vibrators [78.4 h]; Water Tanker [78.4 h]; JCB [78.4 h] | 5,759.91 | 0 | 0 | 0.002466885 | 6 | RPI - CONS | Z2 | PW | MECH | 1.3.3.20 | CONS | CONS | ZONE-3 | ROAD-4 | MECH | PW |
| CON-Z3-UT-PW-VC-0980 |  | Installation of Roof Slab, Manhole Cover, Accessories & Finishes | 4d | 2017-04-23 | 2017-04-27 | CON-Z3-UT-PW-VC-0960, CON-Z3-UT-PW-VC-0870 SS, CON-Z3-UT-PW-VC-0970 | 30.8d | 0d | Common Labor / Helper [260 h]; Finishing Work Crew [52 h] | 9,215.85 |  |  |  |  |  |  |  |  | 1.3.3.20 | CONS | CONS | ZONE-3 | ROAD-4 | MECH | PW |
|  | 7 | **Chamber - New VB Type B2 at Road 4/Road 2 junction** |  | 2017-03-06 | 2017-05-02 |  |  |  |  |  |  |  |  |  |  |  |  |  |  |  |  |  |  |  |  |
| CON-Z3-UT-PW-VC-0890 |  | Excavation and Compaction | 1.6d | 2017-03-06 | 2017-03-07 | CON-Z3-UT-PW-VC-0750 | 50.8d | 0d | Operator - Excavator [26 h] | 5,759.91 | 0 | 0 | 0.0030836221 | 6 | RPI - CONS | Z2 | PW | MECH | 1.3.3.20 | CONS | CONS | ZONE-3 | ROAD-4 | MECH | PW |
| CON-Z3-UT-PW-VC-0900 |  | Lean concrete | 0.8d | 2017-03-07 | 2017-03-08 | CON-Z3-UT-PW-VC-0890 | 54.8d | 0d | Concrete Mason [52 h]; Driver - Conc. Transit Mixers [26 h]; Operator - Concrete Pump [26 h] | 3,455.95 | 0 | 0 | 0.0003088871 | 6 | RPI - CONS | Z2 | PW | MECH | 1.3.3.20 | CONS | CONS | ZONE-3 | ROAD-4 | MECH | PW |
| CON-Z3-UT-PW-VC-1020 |  | Formwork for Base Slab | 0.8d | 2017-03-08 | 2017-03-09 | CON-Z3-UT-PW-VC-0900 | 54.8d | 0d | Shuttering Carpenter [78 h]; Common Labor / Helper [52 h] | 5,759.91 | 0 | 0 | 0.000308358 | 6 | RPI - CONS | Z2 | PW | MECH | 1.3.3.20 | CONS | CONS | ZONE-3 | ROAD-4 | MECH | PW |
| CON-Z3-UT-PW-VC-1000 |  | Fabrication & installation of Rebar for Base Slab | 4d | 2017-03-09 | 2017-03-14 | CON-Z3-UT-PW-VC-1020 | 54.8d | 0d | Steel Fixer [78 h] | 5,759.91 | 0 | 0 | 0.0015418111 | 6 | RPI - CONS | Z2 | PW | MECH | 1.3.3.20 | CONS | CONS | ZONE-3 | ROAD-4 | MECH | PW |
| CON-Z3-UT-PW-VC-1010 |  | Fabrication & installation of Rebar for Side walls | 4d | 2017-03-14 | 2017-03-19 | CON-Z3-UT-PW-VC-1000 | 54.8d | 0d | Steel Fixer [78 h] | 5,759.91 | 0 | 0 | 0.0030836221 | 6 | RPI - CONS | Z2 | PW | MECH | 1.3.3.20 | CONS | CONS | ZONE-3 | ROAD-4 | MECH | PW |
| CON-Z3-UT-PW-VC-1040 |  | Formwork for side walls | 4d | 2017-03-15 | 2017-03-19 | CON-Z3-UT-PW-VC-1010 SS+0.8d | 54.8d | 0d | Common Labor / Helper [26 h]; Scaffolder [52 h]; Shuttering Carpenter [78 h] | 11,519.82 | 0 | 0 | 0.0015418111 | 6 | RPI - CONS | Z2 | PW | MECH | 1.3.3.20 | CONS | CONS | ZONE-3 | ROAD-4 | MECH | PW |
| CON-Z3-UT-PW-VC-1030 |  | Concrete pouring for base slab | 0.8d | 2017-03-20 | 2017-03-20 | CON-Z3-UT-PW-VC-1040 | 54.8d | 0d | Concrete Mason [20.8 h]; Common Labor / Helper [26 h]; Finishing Work Crew [20.8 h]; Driver - Conc. Transit Mixers [26 h]; Operator - Concrete Pump [26 h] | 5,759.91 | 0 | 0 | 0.0015418111 | 6 | RPI - CONS | Z2 | PW | MECH | 1.3.3.20 | CONS | CONS | ZONE-3 | ROAD-4 | MECH | PW |
| CON-Z3-UT-PW-VC-1050 |  | Concrete pouring for Side Wall | 0.8d | 2017-03-20 | 2017-03-21 | CON-Z3-UT-PW-VC-1030 | 54.8d | 0d | Concrete Mason [78 h]; Common Labor / Helper [26 h]; Finishing Work Crew [52 h]; Driver - Conc. Transit Mixers [26 h]; Operator - Concrete Pump [26 h] | 11,519.82 | 0 | 0 | 0.0040086961 | 6 | RPI - CONS | Z2 | PW | MECH | 1.3.3.20 | CONS | CONS | ZONE-3 | ROAD-4 | MECH | PW |
| CON-Z3-UT-PW-VC-1060 |  | Formwork removal and concrete patching | 1.6d | 2017-03-21 | 2017-03-23 | CON-Z3-UT-PW-VC-1050 | 54.8d | 0d | Shuttering Carpenter [78 h]; Scaffolder [26 h]; Finishing Work Crew [52 h] | 2,303.96 | 0 | 0 | 0.0015418111 | 6 | RPI - CONS | Z2 | PW | MECH | 1.3.3.20 | CONS | CONS | ZONE-3 | ROAD-4 | MECH | PW |
| CON-Z3-UT-PW-VC-1110 |  | Concrete Supports | 0.8d | 2017-03-23 | 2017-03-23 | CON-Z3-UT-PW-VC-1060 | 54.8d | 0d | Shuttering Carpenter [26 h]; Concrete Mason [26 h]; Common Labor / Helper [26 h] | 5,759.91 | 0 | 0 | 0.000616716 | 6 | RPI - CONS | Z2 | PW | MECH | 1.3.3.20 | CONS | CONS | ZONE-3 | ROAD-4 | MECH | PW |
| CON-Z3-UT-PW-VC-1100 |  | Installation of Pipe Connections / Closing of Openings | 3.2d | 2017-03-25 | 2017-03-28 | CON-Z3-UT-PW-VC-1110 | 54.8d | 0d | Shuttering Carpenter [26 h]; Concrete Mason [26 h]; Plumber [160 h]; Common Labor / Helper [26 h] | 2,303.96 | 0 | 0 | 0.0055505071 | 6 | RPI - CONS | Z2 | PW | MECH | 1.3.3.20 | CONS | CONS | ZONE-3 | ROAD-4 | MECH | PW |
| CON-Z3-UT-PW-VC-1070 |  | Damp Proof Coating | 0.8d | 2017-03-28 | 2017-03-28 | CON-Z3-UT-PW-VC-1060, CON-Z3-UT-PW-VC-1100 | 56.4d | 0d | Painter [20.8 h]; Water Proofing Crew [20.8 h] | 17,279.73 | 0 | 0 | 0.0015418111 | 6 | RPI - CONS | Z2 | PW | MECH | 1.3.3.20 | CONS | CONS | ZONE-3 | ROAD-4 | MECH | PW |
| CON-Z3-UT-PW-VC-1090 |  | Backfilling & Compaction | 4d | 2017-03-29 | 2017-04-02 | CON-Z3-UT-PW-VC-1070 | 56.4d | 25.6d | Common Labor / Helper [52 h]; Driver - Dump Truck [26 h]; Operator - Bobcat [26 h]; Operator - Roller-Compactor (2~10 Ton) [26 h]; Driver - Water Tanker [26 h]; Operator - JCB [26 h]; Bobcat [28 h]; Plate Compactor [28 h]; Vibrators [28 h]; Water Tanker [28 h]; JCB [28 h] | 3,455.95 | 0 | 0 | 0.0037003381 | 6 | RPI - CONS | Z2 | PW | MECH | 1.3.3.20 | CONS | CONS | ZONE-3 | ROAD-4 | MECH | PW |
| CON-Z3-UT-PW-VC-1120 |  | Instalaltion of Dismantling Joints | 3d | 2017-04-17 | 2017-04-20 | CON-Z3-UT-PW-VC-1100 SS, CON-Z3-UT-PW-VC-0880 | 34d | 0d | Common Labor / Helper [195 h]; RTR Pipe Crew [39 h] | 5,759.91 | 0 | 0 | 0.002466885 | 6 | RPI - CONS | Z2 | PW | MECH | 1.3.3.20 | CONS | CONS | ZONE-3 | ROAD-4 | MECH | PW |
| CON-Z3-UT-PW-VC-2100 |  | Instalaltion of Pressure Guage | 2.4d | 2017-04-17 | 2017-04-20 | CON-Z3-UT-PW-VC-1120 SS | 34d | 0d | Common Labor / Helper [124.8 h] | 5,759.91 |  |  |  |  |  |  |  |  | 1.3.3.20 | CONS | CONS | ZONE-3 | ROAD-4 | MECH | PW |
| CON-Z3-UT-PW-VC-2110 |  | Instalaltion of Gate Valves and Drain Valves | 4d | 2017-04-19 | 2017-04-24 | CON-Z3-UT-PW-VC-2100 SS+1.6d | 34d | 3.2d | Common Labor / Helper [260 h]; RTR Pipe Crew [52 h] | 9,215.85 |  |  |  |  |  |  |  |  | 1.3.3.20 | CONS | CONS | ZONE-3 | ROAD-4 | MECH | PW |
| CON-Z3-UT-PW-VC-2120 |  | Installation of Roof Slab, Manhole Cover, Accessories & Finishes | 4d | 2017-04-27 | 2017-05-02 | CON-Z3-UT-PW-VC-1090 SS, CON-Z3-UT-PW-VC-0980, CON-Z3-UT-PW-VC-2110 | 30.8d | 0d | Common Labor / Helper [260 h]; Finishing Work Crew [52 h] | 8,063.87 |  |  |  |  |  |  |  |  | 1.3.3.20 | CONS | CONS | ZONE-3 | ROAD-4 | MECH | PW |

Notes:
- CON-Z3-UT-PW-VC-0750: Expenses: (New Expense Item) 5759.91
- CON-Z3-UT-PW-VC-0760: Expenses: (New Expense Item) 3455.95
- CON-Z3-UT-PW-VC-0780: Expenses: (New Expense Item) 5759.91
- CON-Z3-UT-PW-VC-0770: Expenses: (New Expense Item) 5759.91
- CON-Z3-UT-PW-VC-0800: Expenses: (New Expense Item) 5759.91
- CON-Z3-UT-PW-VC-0810: Expenses: (New Expense Item) 11519.8
- CON-Z3-UT-PW-VC-0790: Expenses: (New Expense Item) 5759.91
- CON-Z3-UT-PW-VC-0820: Expenses: (New Expense Item) 11519.8
- CON-Z3-UT-PW-VC-0830: Expenses: (New Expense Item) 2303.96
- CON-Z3-UT-PW-VC-0850: Expenses: (New Expense Item) 3455.95
- CON-Z3-UT-PW-VC-0860: Expenses: (New Expense Item) 2303.96
- CON-Z3-UT-PW-VC-0840: Expenses: (New Expense Item) 17279.7
- CON-Z3-UT-PW-VC-0880: Expenses: (New Expense Item) 5759.91
- CON-Z3-UT-PW-VC-0970: Expenses: (New Expense Item) 13823.8
- CON-Z3-UT-PW-VC-0870: Expenses: (New Expense Item) 5759.91
- CON-Z3-UT-PW-VC-0980: Expenses: (New Expense Item) 9215.85
- CON-Z3-UT-PW-VC-0890: Expenses: (New Expense Item) 5759.91
- CON-Z3-UT-PW-VC-0900: Expenses: (New Expense Item) 3455.95
- CON-Z3-UT-PW-VC-1020: Expenses: (New Expense Item) 5759.91
- CON-Z3-UT-PW-VC-1000: Expenses: (New Expense Item) 5759.91
- CON-Z3-UT-PW-VC-1010: Expenses: (New Expense Item) 5759.91
- CON-Z3-UT-PW-VC-1040: Expenses: (New Expense Item) 11519.8
- CON-Z3-UT-PW-VC-1030: Expenses: (New Expense Item) 5759.91
- CON-Z3-UT-PW-VC-1050: Expenses: (New Expense Item) 11519.8
- CON-Z3-UT-PW-VC-1060: Expenses: (New Expense Item) 2303.96
- CON-Z3-UT-PW-VC-1110: Expenses: (New Expense Item) 5759.91
- CON-Z3-UT-PW-VC-1100: Expenses: (New Expense Item) 2303.96
- CON-Z3-UT-PW-VC-1070: Expenses: (New Expense Item) 17279.7
- CON-Z3-UT-PW-VC-1090: Expenses: (New Expense Item) 3455.95
- CON-Z3-UT-PW-VC-1120: Expenses: (New Expense Item) 5759.91
- CON-Z3-UT-PW-VC-2100: Expenses: (New Expense Item) 5759.91
- CON-Z3-UT-PW-VC-2110: Expenses: (New Expense Item) 9215.85
- CON-Z3-UT-PW-VC-2120: Expenses: (New Expense Item) 8063.87

| ID | WBS | Activity | Duration | Start | Finish | Predecessors | Total float | Free float | Resources | Cost | Activity Wt% | Weight % | Cost Wt | RPI - PHASE | RPI - CONSTRUCTION | RPI - ZONES | RPI - UTILITY NETWORKS | RPI - TYPE OF WORK | RPI_P2 - BOQ ITEMS | RPI_P2 - CONSTRUCTION | RPI_P2 - PHASE | RPI_P2 - ZONES | RPI_P2 - AREAS | RPI_P2 - DISCIPLINE / WORK TYPE | RPI_P2 - UTILITY NETWORK |
| --- | --- | --- | --- | --- | --- | --- | --- | --- | --- | --- | --- | --- | --- | --- | --- | --- | --- | --- | --- | --- | --- | --- | --- | --- | --- |
|  | 8 | **Chamber - New VB Type C2 at R/A** |  | 2017-03-07 | 2017-05-07 |  |  |  |  |  |  |  |  |  |  |  |  |  |  |  |  |  |  |  |  |
| CON-Z3-UT-PW-VC-1130 |  | Excavation and Compaction | 1.6d | 2017-03-07 | 2017-03-09 | CON-Z3-UT-PW-VC-0890 | 50.8d | 0d | Operator - Excavator [26 h] | 5,759.91 | 0 | 0 | 0.0030836221 | 6 | RPI - CONS | Z2 | PW | MECH | 1.3.3.20 | CONS | CONS | ZONE-3 | ROAD-4 | MECH | PW |
| CON-Z3-UT-PW-VC-1140 |  | Lean concrete | 0.8d | 2017-03-09 | 2017-03-09 | CON-Z3-UT-PW-VC-1130 | 57.2d | 0d | Concrete Mason [52 h]; Driver - Conc. Transit Mixers [26 h]; Operator - Concrete Pump [26 h] | 3,455.95 | 0 | 0 | 0.0003088871 | 6 | RPI - CONS | Z2 | PW | MECH | 1.3.3.20 | CONS | CONS | ZONE-3 | ROAD-4 | MECH | PW |
| CON-Z3-UT-PW-VC-1170 |  | Formwork for Base Slab | 0.8d | 2017-03-11 | 2017-03-11 | CON-Z3-UT-PW-VC-1140 | 57.2d | 0d | Shuttering Carpenter [31.2 h]; Common Labor / Helper [20.8 h] | 5,759.91 | 0 | 0 | 0.000308358 | 6 | RPI - CONS | Z2 | PW | MECH | 1.3.3.20 | CONS | CONS | ZONE-3 | ROAD-4 | MECH | PW |
| CON-Z3-UT-PW-VC-1150 |  | Fabrication & installation of Rebar for Base Slab | 4d | 2017-03-11 | 2017-03-15 | CON-Z3-UT-PW-VC-1170 | 57.2d | 0d | Steel Fixer [78 h] | 5,759.91 | 0 | 0 | 0.0015418111 | 6 | RPI - CONS | Z2 | PW | MECH | 1.3.3.20 | CONS | CONS | ZONE-3 | ROAD-4 | MECH | PW |
| CON-Z3-UT-PW-VC-1160 |  | Fabrication & installation of Rebar for Side walls | 4d | 2017-03-15 | 2017-03-20 | CON-Z3-UT-PW-VC-1150 | 57.2d | 0d | Steel Fixer [78 h] | 5,759.91 | 0 | 0 | 0.0030836221 | 6 | RPI - CONS | Z2 | PW | MECH | 1.3.3.20 | CONS | CONS | ZONE-3 | ROAD-4 | MECH | PW |
| CON-Z3-UT-PW-VC-1190 |  | Formwork for side walls | 4d | 2017-03-16 | 2017-03-21 | CON-Z3-UT-PW-VC-1160 SS+0.8d | 57.2d | 0d | Shuttering Carpenter [78 h]; Common Labor / Helper [26 h]; Scaffolder [52 h] | 11,519.82 | 0 | 0 | 0.0015418111 | 6 | RPI - CONS | Z2 | PW | MECH | 1.3.3.20 | CONS | CONS | ZONE-3 | ROAD-4 | MECH | PW |
| CON-Z3-UT-PW-VC-1180 |  | Concrete pouring for base slab | 0.8d | 2017-03-21 | 2017-03-22 | CON-Z3-UT-PW-VC-1190 | 57.2d | 0d | Concrete Mason [78 h]; Common Labor / Helper [26 h]; Finishing Work Crew [52 h]; Driver - Conc. Transit Mixers [26 h]; Operator - Concrete Pump [26 h] | 5,759.91 | 0 | 0 | 0.0015418111 | 6 | RPI - CONS | Z2 | PW | MECH | 1.3.3.20 | CONS | CONS | ZONE-3 | ROAD-4 | MECH | PW |
| CON-Z3-UT-PW-VC-1200 |  | Concrete pouring for Side Wall | 0.8d | 2017-03-22 | 2017-03-23 | CON-Z3-UT-PW-VC-1180 | 57.2d | 0d | Concrete Mason [78 h]; Common Labor / Helper [26 h]; Finishing Work Crew [52 h]; Driver - Conc. Transit Mixers [26 h]; Operator - Concrete Pump [26 h] | 11,519.82 | 0 | 0 | 0.0040086961 | 6 | RPI - CONS | Z2 | PW | MECH | 1.3.3.20 | CONS | CONS | ZONE-3 | ROAD-4 | MECH | PW |
| CON-Z3-UT-PW-VC-1210 |  | Formwork removal and concrete patching | 1.6d | 2017-03-23 | 2017-03-25 | CON-Z3-UT-PW-VC-1200 | 57.2d | 0d | Shuttering Carpenter [78 h]; Scaffolder [26 h]; Finishing Work Crew [52 h] | 2,303.96 | 0 | 0 | 0.0015418111 | 6 | RPI - CONS | Z2 | PW | MECH | 1.3.3.20 | CONS | CONS | ZONE-3 | ROAD-4 | MECH | PW |
| CON-Z3-UT-PW-VC-1220 |  | Concrete Supports | 0.8d | 2017-03-25 | 2017-03-26 | CON-Z3-UT-PW-VC-1210 | 57.2d | 0d | Shuttering Carpenter [26 h]; Concrete Mason [26 h]; Common Labor / Helper [26 h] | 17,279.73 | 0 | 0 | 0.000616716 | 6 | RPI - CONS | Z2 | PW | MECH | 1.3.3.20 | CONS | CONS | ZONE-3 | ROAD-4 | MECH | PW |
| CON-Z3-UT-PW-VC-1240 |  | Installation of Pipe Connections / Closing of Openings | 3.2d | 2017-03-26 | 2017-03-29 | CON-Z3-UT-PW-VC-1220 | 57.2d | 0d | Shuttering Carpenter [26 h]; Concrete Mason [26 h]; Plumber [160 h]; Common Labor / Helper [26 h] | 2,303.96 | 0 | 0 | 0.0055505071 | 6 | RPI - CONS | Z2 | PW | MECH | 1.3.3.20 | CONS | CONS | ZONE-3 | ROAD-4 | MECH | PW |
| CON-Z3-UT-PW-VC-5450 |  | Instalaltion of Dismantling Joints | 3d | 2017-03-26 | 2017-03-29 | CON-Z3-UT-PW-VC-1240 SS | 57.2d | 0d | Common Labor / Helper [26 h]; RTR Pipe Crew [26 h] | 5,759.91 | 0 | 0 | 0.002466885 | 6 | RPI - CONS | Z2 | PW | MECH | 1.3.3.20 | CONS | CONS | ZONE-3 | ROAD-4 | MECH | PW |
| CON-Z3-UT-PW-VC-5460 |  | Instalaltion of Pressure Guage | 2.4d | 2017-03-26 | 2017-03-28 | CON-Z3-UT-PW-VC-5450 SS | 57.2d | 0d | Common Labor / Helper [26 h] | 5,759.91 |  |  |  |  |  |  |  |  | 1.3.3.20 | CONS | CONS | ZONE-3 | ROAD-4 | MECH | PW |
| CON-Z3-UT-PW-VC-5470 |  | Instalaltion of Butterfly Valves,Gate Valves and Drain Valves | 4d | 2017-03-28 | 2017-04-02 | CON-Z3-UT-PW-VC-5460 SS+1.6d, PR-Z3-UT-PW-128-0080 | 57.2d | 26.4d | Concrete Mason [26 h]; RTR Pipe Crew [26 h] | 9,215.85 |  |  |  |  |  |  |  |  | 1.3.3.20 | CONS | CONS | ZONE-3 | ROAD-4 | MECH | PW |
| CON-Z3-UT-PW-VC-1230 |  | Damp Proof Coating | 0.8d | 2017-03-29 | 2017-03-30 | CON-Z3-UT-PW-VC-1240, CON-Z3-UT-PW-VC-1210 | 58.8d | 0d | Painter [20.8 h]; Water Proofing Crew [20.8 h] | 3,455.95 | 0 | 0 | 0.0015418111 | 6 | RPI - CONS | Z2 | PW | MECH | 1.3.3.20 | CONS | CONS | ZONE-3 | ROAD-4 | MECH | PW |
| CON-Z3-UT-PW-VC-1250 |  | Backfilling & Compaction | 4d | 2017-03-30 | 2017-04-04 | CON-Z3-UT-PW-VC-1230 | 58.8d | 28d | Common Labor / Helper [260 h]; Driver - Dump Truck [52 h]; Operator - Bobcat [52 h]; Operator - Roller-Compactor (2~10 Ton) [52 h]; Driver - Water Tanker [52 h]; Operator - JCB [52 h]; Bobcat [56 h]; Plate Compactor [56 h]; Vibrators [56 h]; Water Tanker [56 h]; JCB [56 h] | 5,759.91 | 0 | 0 | 0.0037003381 | 6 | RPI - CONS | Z2 | PW | MECH | 1.3.3.20 | CONS | CONS | ZONE-3 | ROAD-4 | MECH | PW |
| CON-Z3-UT-PW-VC-5480 |  | Installation of Roof Slab, Manhole Cover, Accessories & Finishes | 4d | 2017-05-02 | 2017-05-07 | CON-Z3-UT-PW-VC-5470, CON-Z3-UT-PW-VC-1250 SS, CON-Z3-UT-PW-VC-2120 | 30.8d | 0d | Common Labor / Helper [52 h]; Finishing Work Crew [52 h] | 8,063.87 |  |  |  |  |  |  |  |  | 1.3.3.20 | CONS | CONS | ZONE-3 | ROAD-4 | MECH | PW |
|  | 9 | **Chamber - New VB Type A2 at Road 3/Road A junction** |  | 2017-03-09 | 2017-05-11 |  |  |  |  |  |  |  |  |  |  |  |  |  |  |  |  |  |  |  |  |
| CON-Z3-UT-PW-VC-1270 |  | Excavation and Compaction | 1.6d | 2017-03-09 | 2017-03-11 | CON-Z3-UT-PW-VC-1130, CON-Z3-UT-PW-PL-0280 | 50.8d | 0d | Operator - Excavator [26 h] | 5,759.91 | 0 | 0 | 0.0030836221 | 6 | RPI - CONS | Z2 | PW | MECH | 1.3.3.20 | CONS | CONS | ZONE-3 | ROAD-3 | MECH | PW |
| CON-Z3-UT-PW-VC-1280 |  | Lean concrete | 0.8d | 2017-03-11 | 2017-03-12 | CON-Z3-UT-PW-VC-1270 | 59.6d | 0d | Concrete Mason [52 h]; Driver - Conc. Transit Mixers [26 h]; Operator - Concrete Pump [26 h] | 3,455.95 | 0 | 0 | 0.0003088871 | 6 | RPI - CONS | Z2 | PW | MECH | 1.3.3.20 | CONS | CONS | ZONE-3 | ROAD-3 | MECH | PW |
| CON-Z3-UT-PW-VC-1310 |  | Formwork for Base Slab | 0.8d | 2017-03-12 | 2017-03-13 | CON-Z3-UT-PW-VC-1280 | 59.6d | 0d | Shuttering Carpenter [78 h]; Common Labor / Helper [52 h] | 5,759.91 | 0 | 0 | 0.000308358 | 6 | RPI - CONS | Z2 | PW | MECH | 1.3.3.20 | CONS | CONS | ZONE-3 | ROAD-3 | MECH | PW |
| CON-Z3-UT-PW-VC-1290 |  | Fabrication & installation of Rebar for Base Slab | 4d | 2017-03-13 | 2017-03-18 | CON-Z3-UT-PW-VC-1310 | 59.6d | 0d | Steel Fixer [78 h] | 5,759.91 | 0 | 0 | 0.0015418111 | 6 | RPI - CONS | Z2 | PW | MECH | 1.3.3.20 | CONS | CONS | ZONE-3 | ROAD-3 | MECH | PW |
| CON-Z3-UT-PW-VC-1300 |  | Fabrication & installation of Rebar for Side walls | 4d | 2017-03-18 | 2017-03-22 | CON-Z3-UT-PW-VC-1290 | 59.6d | 0d | Steel Fixer [78 h] | 5,759.91 | 0 | 0 | 0.0030836221 | 6 | RPI - CONS | Z2 | PW | MECH | 1.3.3.20 | CONS | CONS | ZONE-3 | ROAD-3 | MECH | PW |
| CON-Z3-UT-PW-VC-1330 |  | Formwork for side walls | 4d | 2017-03-19 | 2017-03-23 | CON-Z3-UT-PW-VC-1300 SS+0.8d | 59.6d | 0d | Shuttering Carpenter [78 h]; Common Labor / Helper [26 h]; Scaffolder [52 h] | 11,519.82 | 0 | 0 | 0.0015418111 | 6 | RPI - CONS | Z2 | PW | MECH | 1.3.3.20 | CONS | CONS | ZONE-3 | ROAD-3 | MECH | PW |
| CON-Z3-UT-PW-VC-1320 |  | Concrete pouring for base slab | 0.8d | 2017-03-23 | 2017-03-23 | CON-Z3-UT-PW-VC-1330 | 59.6d | 0d | Concrete Mason [20.8 h]; Common Labor / Helper [26 h]; Finishing Work Crew [20.8 h]; Driver - Conc. Transit Mixers [26 h]; Operator - Concrete Pump [26 h] | 5,759.91 | 0 | 0 | 0.0015418111 | 6 | RPI - CONS | Z2 | PW | MECH | 1.3.3.20 | CONS | CONS | ZONE-3 | ROAD-3 | MECH | PW |
| CON-Z3-UT-PW-VC-1340 |  | Concrete pouring for Side Wall | 0.8d | 2017-03-25 | 2017-03-25 | CON-Z3-UT-PW-VC-1320 | 59.6d | 0d | Concrete Mason [20.8 h]; Common Labor / Helper [26 h]; Finishing Work Crew [20.8 h]; Driver - Conc. Transit Mixers [26 h]; Operator - Concrete Pump [26 h] | 11,519.82 | 0 | 0 | 0.0040086961 | 6 | RPI - CONS | Z2 | PW | MECH | 1.3.3.20 | CONS | CONS | ZONE-3 | ROAD-3 | MECH | PW |
| CON-Z3-UT-PW-VC-1350 |  | Formwork removal and concrete patching | 1.6d | 2017-03-25 | 2017-03-27 | CON-Z3-UT-PW-VC-1340 | 59.6d | 0d | Shuttering Carpenter [78 h]; Scaffolder [26 h]; Finishing Work Crew [52 h] | 2,303.96 | 0 | 0 | 0.0015418111 | 6 | RPI - CONS | Z2 | PW | MECH | 1.3.3.20 | CONS | CONS | ZONE-3 | ROAD-3 | MECH | PW |
| CON-Z3-UT-PW-VC-1370 |  | Concrete Supports | 0.8d | 2017-03-27 | 2017-03-28 | CON-Z3-UT-PW-VC-1350 | 59.6d | 0d | Shuttering Carpenter [26 h]; Concrete Mason [26 h]; Common Labor / Helper [26 h] | 3,455.95 | 0 | 0 | 0.000616716 | 6 | RPI - CONS | Z2 | PW | MECH | 1.3.3.20 | CONS | CONS | ZONE-3 | ROAD-3 | MECH | PW |
| CON-Z3-UT-PW-VC-1360 |  | Installation of Pipe Connections / Closing of Openings | 3.2d | 2017-03-28 | 2017-04-01 | CON-Z3-UT-PW-VC-1370 | 59.6d | 0d | Shuttering Carpenter [26 h]; Concrete Mason [26 h]; Plumber [160 h]; Common Labor / Helper [26 h] | 17,279.73 | 0 | 0 | 0.0055505071 | 6 | RPI - CONS | Z2 | PW | MECH | 1.3.3.20 | CONS | CONS | ZONE-3 | ROAD-3 | MECH | PW |
| CON-Z3-UT-PW-VC-5490 |  | Instalaltion of Dismantling Joints | 3d | 2017-03-28 | 2017-04-01 | CON-Z3-UT-PW-VC-1360 SS | 59.6d | 0d | Common Labor / Helper [26 h]; RTR Pipe Crew [26 h] | 5,759.91 | 0 | 0 | 0.002466885 | 6 | RPI - CONS | Z2 | PW | MECH | 1.3.3.20 | CONS | CONS | ZONE-3 | ROAD-3 | MECH | PW |
| CON-Z3-UT-PW-VC-5500 |  | Instalaltion of Pressure Guage | 2.4d | 2017-03-28 | 2017-03-30 | CON-Z3-UT-PW-VC-5490 SS | 59.6d | 0d | Common Labor / Helper [26 h] | 5,759.91 |  |  |  |  |  |  |  |  | 1.3.3.20 | CONS | CONS | ZONE-3 | ROAD-3 | MECH | PW |
| CON-Z3-UT-PW-VC-5510 |  | Instalaltion of Butterfly Valves,Gate Valves and Drain Valves | 4d | 2017-03-29 | 2017-04-03 | CON-Z3-UT-PW-VC-5500 SS+1.6d | 59.6d | 28.8d | Concrete Mason [26 h]; RTR Pipe Crew [26 h] | 9,215.85 |  |  |  |  |  |  |  |  | 1.3.3.20 | CONS | CONS | ZONE-3 | ROAD-3 | MECH | PW |
| CON-Z3-UT-PW-VC-1380 |  | Damp Proof Coating | 0.8d | 2017-04-01 | 2017-04-02 | CON-Z3-UT-PW-VC-1350, CON-Z3-UT-PW-VC-1360 | 61.2d | 0d | Painter [96 h]; Water Proofing Crew [62.4 h] | 2,303.96 | 0 | 0 | 0.0015418111 | 6 | RPI - CONS | Z2 | PW | MECH | 1.3.3.20 | CONS | CONS | ZONE-3 | ROAD-3 | MECH | PW |
| CON-Z3-UT-PW-VC-1390 |  | Backfilling & Compaction | 4d | 2017-04-02 | 2017-04-06 | CON-Z3-UT-PW-VC-1380 | 61.2d | 30.4d | Driver - Dump Truck [52 h]; Operator - Bobcat [52 h]; Operator - Roller-Compactor (2~10 Ton) [52 h]; Driver - Water Tanker [52 h]; Operator - JCB [52 h]; Bobcat [56 h]; Plate Compactor [56 h]; Vibrators [56 h]; Water Tanker [56 h]; JCB [56 h]; Common Labor / Helper [260 h] | 5,759.91 | 0 | 0 | 0.0037003381 | 6 | RPI - CONS | Z2 | PW | MECH | 1.3.3.20 | CONS | CONS | ZONE-3 | ROAD-3 | MECH | PW |
| CON-Z3-UT-PW-VC-5520 |  | Installation of Roof Slab, Manhole Cover, Accessories & Finishes | 4d | 2017-05-07 | 2017-05-11 | CON-Z3-UT-PW-VC-5510, CON-Z3-UT-PW-VC-5480, CON-Z3-UT-PW-VC-1390 SS | 30.8d | 0d | Common Labor / Helper [52 h]; Finishing Work Crew [52 h] | 8,063.87 |  |  |  |  |  |  |  |  | 1.3.3.20 | CONS | CONS | ZONE-3 | ROAD-3 | MECH | PW |

Notes:
- CON-Z3-UT-PW-VC-1130: Expenses: (New Expense Item) 5759.91
- CON-Z3-UT-PW-VC-1140: Expenses: (New Expense Item) 3455.95
- CON-Z3-UT-PW-VC-1170: Expenses: (New Expense Item) 5759.91
- CON-Z3-UT-PW-VC-1150: Expenses: (New Expense Item) 5759.91
- CON-Z3-UT-PW-VC-1160: Expenses: (New Expense Item) 5759.91
- CON-Z3-UT-PW-VC-1190: Expenses: (New Expense Item) 11519.8
- CON-Z3-UT-PW-VC-1180: Expenses: (New Expense Item) 5759.91
- CON-Z3-UT-PW-VC-1200: Expenses: (New Expense Item) 11519.8
- CON-Z3-UT-PW-VC-1210: Expenses: (New Expense Item) 2303.96
- CON-Z3-UT-PW-VC-1220: Expenses: (New Expense Item) 17279.7
- CON-Z3-UT-PW-VC-1240: Expenses: (New Expense Item) 2303.96
- CON-Z3-UT-PW-VC-5450: Expenses: (New Expense Item) 5759.91
- CON-Z3-UT-PW-VC-5460: Expenses: (New Expense Item) 5759.91
- CON-Z3-UT-PW-VC-5470: Expenses: (New Expense Item) 9215.85
- CON-Z3-UT-PW-VC-1230: Expenses: (New Expense Item) 3455.95
- CON-Z3-UT-PW-VC-1250: Expenses: (New Expense Item) 5759.91
- CON-Z3-UT-PW-VC-5480: Expenses: (New Expense Item) 8063.87
- CON-Z3-UT-PW-VC-1270: Expenses: (New Expense Item) 5759.91
- CON-Z3-UT-PW-VC-1280: Expenses: (New Expense Item) 3455.95
- CON-Z3-UT-PW-VC-1310: Expenses: (New Expense Item) 5759.91
- CON-Z3-UT-PW-VC-1290: Expenses: (New Expense Item) 5759.91
- CON-Z3-UT-PW-VC-1300: Expenses: (New Expense Item) 5759.91
- CON-Z3-UT-PW-VC-1330: Expenses: (New Expense Item) 11519.8
- CON-Z3-UT-PW-VC-1320: Expenses: (New Expense Item) 5759.91
- CON-Z3-UT-PW-VC-1340: Expenses: (New Expense Item) 11519.8
- CON-Z3-UT-PW-VC-1350: Expenses: (New Expense Item) 2303.96
- CON-Z3-UT-PW-VC-1370: Expenses: (New Expense Item) 3455.95
- CON-Z3-UT-PW-VC-1360: Expenses: (New Expense Item) 17279.7
- CON-Z3-UT-PW-VC-5490: Expenses: (New Expense Item) 5759.91
- CON-Z3-UT-PW-VC-5500: Expenses: (New Expense Item) 5759.91
- CON-Z3-UT-PW-VC-5510: Expenses: (New Expense Item) 9215.85
- CON-Z3-UT-PW-VC-1380: Expenses: (New Expense Item) 2303.96
- CON-Z3-UT-PW-VC-1390: Expenses: (New Expense Item) 5759.91
- CON-Z3-UT-PW-VC-5520: Expenses: (New Expense Item) 8063.87

| ID | WBS | Activity | Duration | Start | Finish | Predecessors | Total float | Free float | Resources | Cost | Activity Wt% | Weight % | Cost Wt | RPI - PHASE | RPI - CONSTRUCTION | RPI - ZONES | RPI - UTILITY NETWORKS | RPI - TYPE OF WORK | RPI_P2 - BOQ ITEMS | RPI_P2 - CONSTRUCTION | RPI_P2 - PHASE | RPI_P2 - ZONES | RPI_P2 - AREAS | RPI_P2 - DISCIPLINE / WORK TYPE | RPI_P2 - UTILITY NETWORK |
| --- | --- | --- | --- | --- | --- | --- | --- | --- | --- | --- | --- | --- | --- | --- | --- | --- | --- | --- | --- | --- | --- | --- | --- | --- | --- |
|  | 10 | **Washout Chamber at Road A (2nd)** |  | 2017-03-11 | 2017-05-14 |  |  |  |  |  |  |  |  |  |  |  |  |  |  |  |  |  |  |  |  |
| CON-Z3-UT-PW-VC-1410 |  | Excavation and Compaction | 1.6d | 2017-03-11 | 2017-03-13 | CON-Z3-UT-PW-PL-0070, CON-Z3-UT-PW-VC-1270 | 50.8d | 0d | Operator - Excavator [26 h] | 5,759.91 | 0 | 0 | 0.0030836221 | 6 | RPI - CONS | Z2 | PW | MECH | 1.3.3.20 | CONS | CONS | ZONE-3 | ROAD-A | MECH | PW |
| CON-Z3-UT-PW-VC-1420 |  | Lean concrete | 0.8d | 2017-03-13 | 2017-03-14 | CON-Z3-UT-PW-VC-1410 | 50.8d | 0d | Concrete Mason [52 h]; Driver - Conc. Transit Mixers [26 h]; Operator - Concrete Pump [26 h] | 3,455.95 | 0 | 0 | 0.0003088871 | 6 | RPI - CONS | Z2 | PW | MECH | 1.3.3.20 | CONS | CONS | ZONE-3 | ROAD-A | MECH | PW |
| CON-Z3-UT-PW-VC-1450 |  | Formwork for Base Slab | 0.8d | 2017-03-14 | 2017-03-14 | CON-Z3-UT-PW-VC-1420 | 50.8d | 0d | Shuttering Carpenter [78 h]; Common Labor / Helper [52 h] | 5,759.91 | 0 | 0 | 0.000308358 | 6 | RPI - CONS | Z2 | PW | MECH | 1.3.3.20 | CONS | CONS | ZONE-3 | ROAD-A | MECH | PW |
| CON-Z3-UT-PW-VC-1430 |  | Fabrication & installation of Rebar for Base Slab | 4d | 2017-03-15 | 2017-03-19 | CON-Z3-UT-PW-VC-1450 | 50.8d | 0d | Steel Fixer [78 h] | 5,759.91 | 0 | 0 | 0.0015418111 | 6 | RPI - CONS | Z2 | PW | MECH | 1.3.3.20 | CONS | CONS | ZONE-3 | ROAD-A | MECH | PW |
| CON-Z3-UT-PW-VC-1440 |  | Fabrication & installation of Rebar for Side walls | 4d | 2017-03-20 | 2017-03-23 | CON-Z3-UT-PW-VC-1430 | 50.8d | 0d | Steel Fixer [78 h] | 5,759.91 | 0 | 0 | 0.0030836221 | 6 | RPI - CONS | Z2 | PW | MECH | 1.3.3.20 | CONS | CONS | ZONE-3 | ROAD-A | MECH | PW |
| CON-Z3-UT-PW-VC-1470 |  | Formwork for side walls | 4d | 2017-03-20 | 2017-03-25 | CON-Z3-UT-PW-VC-1440 SS+0.8d | 50.8d | 0d | Shuttering Carpenter [78 h]; Common Labor / Helper [26 h]; Scaffolder [52 h] | 17,279.73 | 0 | 0 | 0.0015418111 | 6 | RPI - CONS | Z2 | PW | MECH | 1.3.3.20 | CONS | CONS | ZONE-3 | ROAD-A | MECH | PW |
| CON-Z3-UT-PW-VC-1460 |  | Concrete pouring for base slab | 0.8d | 2017-03-25 | 2017-03-26 | CON-Z3-UT-PW-VC-1470 | 50.8d | 0d | Concrete Mason [20.8 h]; Common Labor / Helper [26 h]; Finishing Work Crew [20.8 h]; Driver - Conc. Transit Mixers [26 h]; Operator - Concrete Pump [26 h] | 5,759.91 | 0 | 0 | 0.0015418111 | 6 | RPI - CONS | Z2 | PW | MECH | 1.3.3.20 | CONS | CONS | ZONE-3 | ROAD-A | MECH | PW |
| CON-Z3-UT-PW-VC-1480 |  | Concrete pouring for Side Wall | 0.8d | 2017-03-26 | 2017-03-27 | CON-Z3-UT-PW-VC-1460 | 50.8d | 0d | Concrete Mason [20.8 h]; Common Labor / Helper [26 h]; Finishing Work Crew [20.8 h]; Driver - Conc. Transit Mixers [26 h]; Operator - Concrete Pump [26 h] | 17,279.73 | 0 | 0 | 0.0040086961 | 6 | RPI - CONS | Z2 | PW | MECH | 1.3.3.20 | CONS | CONS | ZONE-3 | ROAD-A | MECH | PW |
| CON-Z3-UT-PW-VC-1490 |  | Formwork removal and concrete patching | 1.6d | 2017-03-27 | 2017-03-28 | CON-Z3-UT-PW-VC-1480 | 50.8d | 0d | Shuttering Carpenter [78 h]; Scaffolder [26 h]; Finishing Work Crew [52 h] | 2,303.96 | 0 | 0 | 0.0015418111 | 6 | RPI - CONS | Z2 | PW | MECH | 1.3.3.20 | CONS | CONS | ZONE-3 | ROAD-A | MECH | PW |
| CON-Z3-UT-PW-VC-1510 |  | Concrete Supports | 0.8d | 2017-03-29 | 2017-03-29 | CON-Z3-UT-PW-VC-1490 | 50.8d | 0d | Shuttering Carpenter [26 h]; Concrete Mason [26 h]; Common Labor / Helper [26 h] | 3,455.95 | 0 | 0 | 0.000616716 | 6 | RPI - CONS | Z2 | PW | MECH | 1.3.3.20 | CONS | CONS | ZONE-3 | ROAD-A | MECH | PW |
| CON-Z3-UT-PW-VC-1500 |  | Installation of Valves / Pipe Connections / Closing of Openings | 3.2d | 2017-03-29 | 2017-04-02 | CON-Z3-UT-PW-VC-1510, PR-Z3-UT-PW-129-0080 | 50.8d | 0d | Shuttering Carpenter [26 h]; Concrete Mason [26 h]; Common Labor / Helper [26 h]; RTR Pipe Crew [26 h] | 23,039.64 | 0 | 0 | 0.0055505071 | 6 | RPI - CONS | Z2 | PW | MECH | 1.3.3.20 | CONS | CONS | ZONE-3 | ROAD-A | MECH | PW |
| CON-Z3-UT-PW-VC-1520 |  | Damp Proof Coating | 0.8d | 2017-04-03 | 2017-04-03 | CON-Z3-UT-PW-VC-1490, CON-Z3-UT-PW-VC-1500 | 50.8d | 0d | Painter [80 h]; Water Proofing Crew [52 h] | 2,303.96 | 0 | 0 | 0.0015418111 | 6 | RPI - CONS | Z2 | PW | MECH | 1.3.3.20 | CONS | CONS | ZONE-3 | ROAD-A | MECH | PW |
| CON-Z3-UT-PW-VC-1530 |  | Backfilling & Compaction | 4d | 2017-04-03 | 2017-04-08 | CON-Z3-UT-PW-VC-1520 | 50.8d | 20d | Common Labor / Helper [260 h]; Driver - Dump Truck [52 h]; Operator - Bobcat [52 h]; Operator - Roller-Compactor (2~10 Ton) [52 h]; Driver - Water Tanker [52 h]; Operator - JCB [52 h]; Bobcat [56 h]; Plate Compactor [56 h]; Vibrators [56 h]; Water Tanker [56 h]; JCB [56 h] | 5,759.91 | 0 | 0 | 0.0037003381 | 6 | RPI - CONS | Z2 | PW | MECH | 1.3.3.20 | CONS | CONS | ZONE-3 | ROAD-A | MECH | PW |
| CON-Z3-UT-PW-VC-1540 |  | Installation of Roof Slab, Manhole Cover, Accessories & Finishes | 5.6d | 2017-05-07 | 2017-05-14 | CON-Z3-UT-PW-VC-1530 FS+4.8d, CON-Z3-UT-PW-VC-5520 SS | 30.8d | 0d | Common Labor / Helper [52 h]; Finishing Work Crew [52 h] | 11,519.82 | 0 | 0 | 0.002466885 | 6 | RPI - CONS | Z2 | PW | MECH | 1.3.3.20 | CONS | CONS | ZONE-3 | ROAD-A | MECH | PW |
|  | 11 | **Chamber - New VB Type C4 at Road A** |  | 2017-03-13 | 2017-05-18 |  |  |  |  |  |  |  |  |  |  |  |  |  |  |  |  |  |  |  |  |
| CON-Z3-UT-PW-VC-1550 |  | Excavation and Compaction | 1.6d | 2017-03-13 | 2017-03-14 | CON-Z3-UT-PW-PL-0070, CON-Z3-UT-PW-VC-1410 | 62d | 0d | Operator - Excavator [26 h] | 5,759.91 | 0 | 0 | 0.0030836221 | 6 | RPI - CONS | Z2 | PW | MECH | 1.3.3.20 | CONS | CONS | ZONE-3 | ROAD-A | MECH | PW |
| CON-Z3-UT-PW-VC-1560 |  | Lean concrete | 0.8d | 2017-03-15 | 2017-03-15 | CON-Z3-UT-PW-VC-1550 | 62d | 0d | Concrete Mason [52 h]; Driver - Conc. Transit Mixers [26 h]; Operator - Concrete Pump [26 h] | 3,455.95 | 0 | 0 | 0.0003088871 | 6 | RPI - CONS | Z2 | PW | MECH | 1.3.3.20 | CONS | CONS | ZONE-3 | ROAD-A | MECH | PW |
| CON-Z3-UT-PW-VC-1590 |  | Formwork for Base Slab | 0.8d | 2017-03-15 | 2017-03-16 | CON-Z3-UT-PW-VC-1560 | 62d | 0d | Shuttering Carpenter [78 h]; Common Labor / Helper [52 h] | 5,759.91 | 0 | 0 | 0.000308358 | 6 | RPI - CONS | Z2 | PW | MECH | 1.3.3.20 | CONS | CONS | ZONE-3 | ROAD-A | MECH | PW |
| CON-Z3-UT-PW-VC-1570 |  | Fabrication & installation of Rebar for Base Slab | 4d | 2017-03-16 | 2017-03-21 | CON-Z3-UT-PW-VC-1590 | 62d | 0d | Steel Fixer [78 h] | 5,759.91 | 0 | 0 | 0.0015418111 | 6 | RPI - CONS | Z2 | PW | MECH | 1.3.3.20 | CONS | CONS | ZONE-3 | ROAD-A | MECH | PW |
| CON-Z3-UT-PW-VC-1580 |  | Fabrication & installation of Rebar for Side walls | 4d | 2017-03-21 | 2017-03-26 | CON-Z3-UT-PW-VC-1570 | 62d | 0d | Steel Fixer [78 h] | 5,759.91 | 0 | 0 | 0.0030836221 | 6 | RPI - CONS | Z2 | PW | MECH | 1.3.3.20 | CONS | CONS | ZONE-3 | ROAD-A | MECH | PW |
| CON-Z3-UT-PW-VC-1610 |  | Formwork for side walls | 4d | 2017-03-22 | 2017-03-27 | CON-Z3-UT-PW-VC-1580 SS+0.8d | 62d | 0d | Shuttering Carpenter [78 h]; Common Labor / Helper [26 h]; Scaffolder [52 h] | 11,519.82 | 0 | 0 | 0.0015418111 | 6 | RPI - CONS | Z2 | PW | MECH | 1.3.3.20 | CONS | CONS | ZONE-3 | ROAD-A | MECH | PW |
| CON-Z3-UT-PW-VC-1600 |  | Concrete pouring for base slab | 0.8d | 2017-03-27 | 2017-03-28 | CON-Z3-UT-PW-VC-1610 | 62d | 0d | Concrete Mason [78 h]; Common Labor / Helper [26 h]; Finishing Work Crew [52 h]; Driver - Conc. Transit Mixers [26 h]; Operator - Concrete Pump [26 h] | 5,759.91 | 0 | 0 | 0.0015418111 | 6 | RPI - CONS | Z2 | PW | MECH | 1.3.3.20 | CONS | CONS | ZONE-3 | ROAD-A | MECH | PW |
| CON-Z3-UT-PW-VC-1620 |  | Concrete pouring for Side Wall | 0.8d | 2017-03-28 | 2017-03-28 | CON-Z3-UT-PW-VC-1600 | 62d | 0d | Concrete Mason [20.8 h]; Common Labor / Helper [26 h]; Finishing Work Crew [20.8 h]; Driver - Conc. Transit Mixers [26 h]; Operator - Concrete Pump [26 h] | 11,519.82 | 0 | 0 | 0.0040086961 | 6 | RPI - CONS | Z2 | PW | MECH | 1.3.3.20 | CONS | CONS | ZONE-3 | ROAD-A | MECH | PW |
| CON-Z3-UT-PW-VC-1630 |  | Formwork removal and concrete patching | 1.6d | 2017-03-29 | 2017-03-30 | CON-Z3-UT-PW-VC-1620 | 62d | 0d | Shuttering Carpenter [78 h]; Scaffolder [26 h]; Finishing Work Crew [52 h] | 2,303.96 | 0 | 0 | 0.0015418111 | 6 | RPI - CONS | Z2 | PW | MECH | 1.3.3.20 | CONS | CONS | ZONE-3 | ROAD-A | MECH | PW |
| CON-Z3-UT-PW-VC-1650 |  | Concrete Supports | 0.8d | 2017-03-30 | 2017-04-01 | CON-Z3-UT-PW-VC-1630 | 62d | 0d | Shuttering Carpenter [41.6 h]; Concrete Mason [41.6 h]; Common Labor / Helper [41.6 h] | 3,455.95 | 0 | 0 | 0.000616716 | 6 | RPI - CONS | Z2 | PW | MECH | 1.3.3.20 | CONS | CONS | ZONE-3 | ROAD-A | MECH | PW |
| CON-Z3-UT-PW-VC-1640 |  | Installation of Pipe Connections / Closing of Openings | 3.2d | 2017-04-01 | 2017-04-04 | CON-Z3-UT-PW-VC-1650 | 62d | 0d | Shuttering Carpenter [320 h]; Concrete Mason [124.8 h]; Plumber [320 h]; Common Labor / Helper [208 h] | 17,279.73 | 0 | 0 | 0.0055505071 | 6 | RPI - CONS | Z2 | PW | MECH | 1.3.3.20 | CONS | CONS | ZONE-3 | ROAD-A | MECH | PW |
| CON-Z3-UT-PW-VC-5530 |  | Instalaltion of Dismantling Joints | 3d | 2017-04-01 | 2017-04-04 | CON-Z3-UT-PW-VC-1640 SS | 62d | 0d | Common Labor / Helper [195 h]; RTR Pipe Crew [39 h] | 5,759.91 | 0 | 0 | 0.002466885 | 6 | RPI - CONS | Z2 | PW | MECH | 1.3.3.20 | CONS | CONS | ZONE-3 | ROAD-A | MECH | PW |
| CON-Z3-UT-PW-VC-5540 |  | Instalaltion of Pressure Guage | 2.4d | 2017-04-01 | 2017-04-03 | CON-Z3-UT-PW-VC-5530 SS | 62d | 0d | Common Labor / Helper [187.2 h] | 5,759.91 |  |  |  |  |  |  |  |  | 1.3.3.20 | CONS | CONS | ZONE-3 | ROAD-A | MECH | PW |
| CON-Z3-UT-PW-VC-5550 |  | Instalaltion of Butterfly Valves,Gate Valves and Drain Valves | 4d | 2017-04-03 | 2017-04-06 | CON-Z3-UT-PW-VC-5540 SS+1.6d | 62d | 31.2d | Concrete Mason [260 h]; RTR Pipe Crew [52 h] | 9,215.85 |  |  |  |  |  |  |  |  | 1.3.3.20 | CONS | CONS | ZONE-3 | ROAD-A | MECH | PW |
| CON-Z3-UT-PW-VC-1660 |  | Damp Proof Coating | 0.8d | 2017-04-04 | 2017-04-05 | CON-Z3-UT-PW-VC-1630, CON-Z3-UT-PW-VC-1640 | 63.6d | 0d | Painter [52 h]; Water Proofing Crew [52 h] | 2,303.96 | 0 | 0 | 0.0015418111 | 6 | RPI - CONS | Z2 | PW | MECH | 1.3.3.20 | CONS | CONS | ZONE-3 | ROAD-A | MECH | PW |
| CON-Z3-UT-PW-VC-1670 |  | Backfilling & Compaction | 4d | 2017-04-05 | 2017-04-10 | CON-Z3-UT-PW-VC-1660 | 63.6d | 32.8d | Common Labor / Helper [260 h]; Driver - Dump Truck [52 h]; Operator - Bobcat [52 h]; Operator - Roller-Compactor (2~10 Ton) [52 h]; Driver - Water Tanker [52 h]; Operator - JCB [52 h]; Bobcat [56 h]; Plate Compactor [56 h]; Vibrators [56 h]; Water Tanker [56 h]; JCB [56 h] | 5,759.91 | 0 | 0 | 0.0037003381 | 6 | RPI - CONS | Z2 | PW | MECH | 1.3.3.20 | CONS | CONS | ZONE-3 | ROAD-A | MECH | PW |
| CON-Z3-UT-PW-VC-5560 |  | Installation of Roof Slab, Manhole Cover, Accessories & Finishes | 4d | 2017-05-14 | 2017-05-18 | CON-Z3-UT-PW-VC-5550, CON-Z3-UT-PW-VC-1540, CON-Z3-UT-PW-VC-1670 SS | 30.8d | 0d | Common Labor / Helper [52 h]; Finishing Work Crew [52 h] | 8,063.87 |  |  |  |  |  |  |  |  | 1.3.3.20 | CONS | CONS | ZONE-3 | ROAD-A | MECH | PW |

Notes:
- CON-Z3-UT-PW-VC-1410: Expenses: (New Expense Item) 5759.91
- CON-Z3-UT-PW-VC-1420: Expenses: (New Expense Item) 3455.95
- CON-Z3-UT-PW-VC-1450: Expenses: (New Expense Item) 5759.91
- CON-Z3-UT-PW-VC-1430: Expenses: (New Expense Item) 5759.91
- CON-Z3-UT-PW-VC-1440: Expenses: (New Expense Item) 5759.91
- CON-Z3-UT-PW-VC-1470: Expenses: (New Expense Item) 17279.7
- CON-Z3-UT-PW-VC-1460: Expenses: (New Expense Item) 5759.91
- CON-Z3-UT-PW-VC-1480: Expenses: (New Expense Item) 17279.7
- CON-Z3-UT-PW-VC-1490: Expenses: (New Expense Item) 2303.96
- CON-Z3-UT-PW-VC-1510: Expenses: (New Expense Item) 3455.95
- CON-Z3-UT-PW-VC-1500: Expenses: (New Expense Item) 23039.6
- CON-Z3-UT-PW-VC-1520: Expenses: (New Expense Item) 2303.96
- CON-Z3-UT-PW-VC-1530: Expenses: (New Expense Item) 5759.91
- CON-Z3-UT-PW-VC-1540: Expenses: (New Expense Item) 11519.8
- CON-Z3-UT-PW-VC-1550: Expenses: (New Expense Item) 5759.91
- CON-Z3-UT-PW-VC-1560: Expenses: (New Expense Item) 3455.95
- CON-Z3-UT-PW-VC-1590: Expenses: (New Expense Item) 5759.91
- CON-Z3-UT-PW-VC-1570: Expenses: (New Expense Item) 5759.91
- CON-Z3-UT-PW-VC-1580: Expenses: (New Expense Item) 5759.91
- CON-Z3-UT-PW-VC-1610: Expenses: (New Expense Item) 11519.8
- CON-Z3-UT-PW-VC-1600: Expenses: (New Expense Item) 5759.91
- CON-Z3-UT-PW-VC-1620: Expenses: (New Expense Item) 11519.8
- CON-Z3-UT-PW-VC-1630: Expenses: (New Expense Item) 2303.96
- CON-Z3-UT-PW-VC-1650: Expenses: (New Expense Item) 3455.95
- CON-Z3-UT-PW-VC-1640: Expenses: (New Expense Item) 17279.7
- CON-Z3-UT-PW-VC-5530: Expenses: (New Expense Item) 5759.91
- CON-Z3-UT-PW-VC-5540: Expenses: (New Expense Item) 5759.91
- CON-Z3-UT-PW-VC-5550: Expenses: (New Expense Item) 9215.85
- CON-Z3-UT-PW-VC-1660: Expenses: (New Expense Item) 2303.96
- CON-Z3-UT-PW-VC-1670: Expenses: (New Expense Item) 5759.91
- CON-Z3-UT-PW-VC-5560: Expenses: (New Expense Item) 8063.87

| ID | WBS | Activity | Duration | Start | Finish | Predecessors | Total float | Free float | Resources | Cost | Activity Wt% | Weight % | Cost Wt | RPI - PHASE | RPI - CONSTRUCTION | RPI - ZONES | RPI - UTILITY NETWORKS | RPI - TYPE OF WORK | RPI_P2 - BOQ ITEMS | RPI_P2 - CONSTRUCTION | RPI_P2 - PHASE | RPI_P2 - ZONES | RPI_P2 - AREAS | RPI_P2 - DISCIPLINE / WORK TYPE | RPI_P2 - UTILITY NETWORK |
| --- | --- | --- | --- | --- | --- | --- | --- | --- | --- | --- | --- | --- | --- | --- | --- | --- | --- | --- | --- | --- | --- | --- | --- | --- | --- |
|  | 12 | **Chamber - New VB Type C2 at Road A/Road 2 Junction** |  | 2017-03-15 | 2017-05-23 |  |  |  |  |  |  |  |  |  |  |  |  |  |  |  |  |  |  |  |  |
| CON-Z3-UT-PW-VC-1690 |  | Excavation and Compaction | 1.6d | 2017-03-15 | 2017-03-16 | CON-Z3-UT-PW-PL-0070, CON-Z3-UT-PW-VC-1550 | 63.6d | 0d | Operator - Excavator [26 h] | 5,759.91 | 0 | 0 | 0.0030836221 | 6 | RPI - CONS | Z2 | PW | MECH | 1.3.3.20 | CONS | CONS | ZONE-3 | ROAD-A | MECH | PW |
| CON-Z3-UT-PW-VC-1700 |  | Lean concrete | 0.8d | 2017-03-16 | 2017-03-18 | CON-Z3-UT-PW-VC-1690 | 64.4d | 0d | Concrete Mason [52 h]; Driver - Conc. Transit Mixers [26 h]; Operator - Concrete Pump [26 h] | 3,455.95 | 0 | 0 | 0.0003088871 | 6 | RPI - CONS | Z2 | PW | MECH | 1.3.3.20 | CONS | CONS | ZONE-3 | ROAD-A | MECH | PW |
| CON-Z3-UT-PW-VC-1730 |  | Formwork for Base Slab | 0.8d | 2017-03-18 | 2017-03-19 | CON-Z3-UT-PW-VC-1700 | 64.4d | 0d | Shuttering Carpenter [78 h]; Common Labor / Helper [52 h] | 5,759.91 | 0 | 0 | 0.000308358 | 6 | RPI - CONS | Z2 | PW | MECH | 1.3.3.20 | CONS | CONS | ZONE-3 | ROAD-A | MECH | PW |
| CON-Z3-UT-PW-VC-1710 |  | Fabrication & installation of Rebar for Base Slab | 4d | 2017-03-19 | 2017-03-23 | CON-Z3-UT-PW-VC-1730 | 64.4d | 0d | Steel Fixer [78 h] | 5,759.91 | 0 | 0 | 0.0015418111 | 6 | RPI - CONS | Z2 | PW | MECH | 1.3.3.20 | CONS | CONS | ZONE-3 | ROAD-A | MECH | PW |
| CON-Z3-UT-PW-VC-1720 |  | Fabrication & installation of Rebar for Side walls | 4d | 2017-03-23 | 2017-03-28 | CON-Z3-UT-PW-VC-1710 | 64.4d | 0d | Steel Fixer [78 h] | 5,759.91 | 0 | 0 | 0.0030836221 | 6 | RPI - CONS | Z2 | PW | MECH | 1.3.3.20 | CONS | CONS | ZONE-3 | ROAD-A | MECH | PW |
| CON-Z3-UT-PW-VC-1750 |  | Formwork for side walls | 4d | 2017-03-25 | 2017-03-28 | CON-Z3-UT-PW-VC-1720 SS+0.8d | 64.4d | 0d | Shuttering Carpenter [78 h]; Common Labor / Helper [26 h]; Scaffolder [52 h] | 11,519.82 | 0 | 0 | 0.0015418111 | 6 | RPI - CONS | Z2 | PW | MECH | 1.3.3.20 | CONS | CONS | ZONE-3 | ROAD-A | MECH | PW |
| CON-Z3-UT-PW-VC-1740 |  | Concrete pouring for base slab | 0.8d | 2017-03-29 | 2017-03-29 | CON-Z3-UT-PW-VC-1750 | 64.4d | 0d | Concrete Mason [20.8 h]; Common Labor / Helper [26 h]; Finishing Work Crew [20.8 h]; Driver - Conc. Transit Mixers [26 h]; Operator - Concrete Pump [26 h] | 5,759.91 | 0 | 0 | 0.0015418111 | 6 | RPI - CONS | Z2 | PW | MECH | 1.3.3.20 | CONS | CONS | ZONE-3 | ROAD-A | MECH | PW |
| CON-Z3-UT-PW-VC-1760 |  | Concrete pouring for Side Wall | 0.8d | 2017-03-29 | 2017-03-30 | CON-Z3-UT-PW-VC-1740 | 64.4d | 0d | Concrete Mason [78 h]; Common Labor / Helper [26 h]; Finishing Work Crew [52 h]; Driver - Conc. Transit Mixers [26 h]; Operator - Concrete Pump [26 h] | 11,519.82 | 0 | 0 | 0.0040086961 | 6 | RPI - CONS | Z2 | PW | MECH | 1.3.3.20 | CONS | CONS | ZONE-3 | ROAD-A | MECH | PW |
| CON-Z3-UT-PW-VC-1770 |  | Formwork removal and concrete patching | 1.6d | 2017-03-30 | 2017-04-02 | CON-Z3-UT-PW-VC-1760 | 64.4d | 0d | Shuttering Carpenter [78 h]; Scaffolder [41.6 h] | 2,303.96 | 0 | 0 | 0.0015418111 | 6 | RPI - CONS | Z2 | PW | MECH | 1.3.3.20 | CONS | CONS | ZONE-3 | ROAD-A | MECH | PW |
| CON-Z3-UT-PW-VC-1790 |  | Concrete Supports | 0.8d | 2017-04-02 | 2017-04-02 | CON-Z3-UT-PW-VC-1770 | 64.4d | 0d | Shuttering Carpenter [40 h]; Concrete Mason [26 h]; Common Labor / Helper [26 h] | 3,455.95 | 0 | 0 | 0.000616716 | 6 | RPI - CONS | Z2 | PW | MECH | 1.3.3.20 | CONS | CONS | ZONE-3 | ROAD-A | MECH | PW |
| CON-Z3-UT-PW-VC-1780 |  | Installation of Pipe Connections / Closing of Openings | 3.2d | 2017-04-03 | 2017-04-06 | CON-Z3-UT-PW-VC-1790 | 64.4d | 0d | Shuttering Carpenter [124.8 h]; Concrete Mason [166.4 h]; Plumber [166.4 h]; Common Labor / Helper [208 h] | 17,279.73 | 0 | 0 | 0.0055505071 | 6 | RPI - CONS | Z2 | PW | MECH | 1.3.3.20 | CONS | CONS | ZONE-3 | ROAD-A | MECH | PW |
| CON-Z3-UT-PW-VC-5570 |  | Instalaltion of Dismantling Joints | 3d | 2017-04-03 | 2017-04-05 | CON-Z3-UT-PW-VC-1780 SS | 64.4d | 0d | Common Labor / Helper [195 h]; RTR Pipe Crew [39 h] | 5,759.91 | 0 | 0 | 0.002466885 | 6 | RPI - CONS | Z2 | PW | MECH | 1.3.3.20 | CONS | CONS | ZONE-3 | ROAD-A | MECH | PW |
| CON-Z3-UT-PW-VC-5580 |  | Instalaltion of Pressure Guage | 2.4d | 2017-04-03 | 2017-04-05 | CON-Z3-UT-PW-VC-5570 SS | 64.4d | 0d | Common Labor / Helper [124.8 h] | 5,759.91 |  |  |  |  |  |  |  |  | 1.3.3.20 | CONS | CONS | ZONE-3 | ROAD-A | MECH | PW |
| CON-Z3-UT-PW-VC-5590 |  | Instalaltion of Butterfly Valves,Gate Valves and Drain Valves | 4d | 2017-04-04 | 2017-04-09 | CON-Z3-UT-PW-VC-5580 SS+1.6d | 64.4d | 33.6d | Concrete Mason [260 h]; RTR Pipe Crew [52 h] | 9,215.85 |  |  |  |  |  |  |  |  | 1.3.3.20 | CONS | CONS | ZONE-3 | ROAD-A | MECH | PW |
| CON-Z3-UT-PW-VC-1800 |  | Damp Proof Coating | 0.8d | 2017-04-06 | 2017-04-06 | CON-Z3-UT-PW-VC-1770, CON-Z3-UT-PW-VC-1780 | 66d | 0d | Painter [52 h]; Water Proofing Crew [52 h] | 2,303.96 | 0 | 0 | 0.0015418111 | 6 | RPI - CONS | Z2 | PW | MECH | 1.3.3.20 | CONS | CONS | ZONE-3 | ROAD-A | MECH | PW |
| CON-Z3-UT-PW-VC-1810 |  | Backfilling & Compaction | 4d | 2017-04-08 | 2017-04-11 | CON-Z3-UT-PW-VC-1800 | 66d | 35.2d | Common Labor / Helper [260 h]; Driver - Dump Truck [52 h]; Operator - Bobcat [52 h]; Operator - Roller-Compactor (2~10 Ton) [52 h]; Driver - Water Tanker [52 h]; Operator - JCB [52 h]; Bobcat [56 h]; Plate Compactor [56 h]; Vibrators [56 h]; Water Tanker [56 h]; JCB [56 h] | 5,759.91 | 0 | 0 | 0.0037003381 | 6 | RPI - CONS | Z2 | PW | MECH | 1.3.3.20 | CONS | CONS | ZONE-3 | ROAD-A | MECH | PW |
| CON-Z3-UT-PW-VC-5600 |  | Installation of Roof Slab, Manhole Cover, Accessories & Finishes | 4d | 2017-05-18 | 2017-05-23 | CON-Z3-UT-PW-VC-5590, CON-Z3-UT-PW-VC-1810 SS, CON-Z3-UT-PW-VC-5560 | 30.8d | 0d | Common Labor / Helper [52 h]; Finishing Work Crew [52 h] | 8,063.87 |  |  |  |  |  |  |  |  | 1.3.3.20 | CONS | CONS | ZONE-3 | ROAD-A | MECH | PW |
|  | 13 | **Chamber - New VB Type A1 at Road A/Road 2 Junction** |  | 2017-03-16 | 2017-05-28 |  |  |  |  |  |  |  |  |  |  |  |  |  |  |  |  |  |  |  |  |
| CON-Z3-UT-PW-VC-1830 |  | Excavation and Compaction | 1.6d | 2017-03-16 | 2017-03-19 | CON-Z3-UT-PW-PL-0070, CON-Z3-UT-PW-VC-1690 | 63.6d | 0d | Operator - Excavator [26 h] | 5,759.91 | 0 | 0 | 0.0030836221 | 6 | RPI - CONS | Z2 | PW | MECH | 1.3.3.20 | CONS | CONS | ZONE-3 | ROAD-A | MECH | PW |
| CON-Z3-UT-PW-VC-1840 |  | Lean concrete | 0.8d | 2017-03-19 | 2017-03-19 | CON-Z3-UT-PW-VC-1830 | 63.6d | 0d | Concrete Mason [52 h]; Driver - Conc. Transit Mixers [26 h]; Operator - Concrete Pump [26 h] | 3,455.95 | 0 | 0 | 0.0003088871 | 6 | RPI - CONS | Z2 | PW | MECH | 1.3.3.20 | CONS | CONS | ZONE-3 | ROAD-A | MECH | PW |
| CON-Z3-UT-PW-VC-1870 |  | Formwork for Base Slab | 0.8d | 2017-03-20 | 2017-03-20 | CON-Z3-UT-PW-VC-1840 | 63.6d | 0d | Shuttering Carpenter [78 h]; Common Labor / Helper [52 h] | 5,759.91 | 0 | 0 | 0.000308358 | 6 | RPI - CONS | Z2 | PW | MECH | 1.3.3.20 | CONS | CONS | ZONE-3 | ROAD-A | MECH | PW |
| CON-Z3-UT-PW-VC-1850 |  | Fabrication & installation of Rebar for Base Slab | 4d | 2017-03-20 | 2017-03-25 | CON-Z3-UT-PW-VC-1870 | 63.6d | 0d | Steel Fixer [78 h] | 5,759.91 | 0 | 0 | 0.0015418111 | 6 | RPI - CONS | Z2 | PW | MECH | 1.3.3.20 | CONS | CONS | ZONE-3 | ROAD-A | MECH | PW |
| CON-Z3-UT-PW-VC-1860 |  | Fabrication & installation of Rebar for Side walls | 4d | 2017-03-25 | 2017-03-29 | CON-Z3-UT-PW-VC-1850 | 63.6d | 0d | Steel Fixer [78 h] | 5,759.91 | 0 | 0 | 0.0030836221 | 6 | RPI - CONS | Z2 | PW | MECH | 1.3.3.20 | CONS | CONS | ZONE-3 | ROAD-A | MECH | PW |
| CON-Z3-UT-PW-VC-1890 |  | Formwork for side walls | 4d | 2017-03-26 | 2017-03-30 | CON-Z3-UT-PW-VC-1860 SS+0.8d | 63.6d | 0d | Shuttering Carpenter [78 h]; Common Labor / Helper [26 h]; Scaffolder [52 h] | 11,519.82 | 0 | 0 | 0.0015418111 | 6 | RPI - CONS | Z2 | PW | MECH | 1.3.3.20 | CONS | CONS | ZONE-3 | ROAD-A | MECH | PW |
| CON-Z3-UT-PW-VC-1880 |  | Concrete pouring for base slab | 0.8d | 2017-03-30 | 2017-04-01 | CON-Z3-UT-PW-VC-1890 | 63.6d | 0d | Concrete Mason [78 h]; Common Labor / Helper [26 h]; Finishing Work Crew [52 h]; Driver - Conc. Transit Mixers [26 h]; Operator - Concrete Pump [26 h] | 5,759.91 | 0 | 0 | 0.0015418111 | 6 | RPI - CONS | Z2 | PW | MECH | 1.3.3.20 | CONS | CONS | ZONE-3 | ROAD-A | MECH | PW |
| CON-Z3-UT-PW-VC-1900 |  | Concrete pouring for Side Wall | 0.8d | 2017-04-01 | 2017-04-02 | CON-Z3-UT-PW-VC-1880 | 63.6d | 0d | Concrete Mason [78 h]; Common Labor / Helper [26 h]; Finishing Work Crew [52 h]; Driver - Conc. Transit Mixers [26 h]; Operator - Concrete Pump [26 h] | 11,519.82 | 0 | 0 | 0.0040086961 | 6 | RPI - CONS | Z2 | PW | MECH | 1.3.3.20 | CONS | CONS | ZONE-3 | ROAD-A | MECH | PW |
| CON-Z3-UT-PW-VC-1910 |  | Formwork removal and concrete patching | 1.6d | 2017-04-02 | 2017-04-03 | CON-Z3-UT-PW-VC-1900 | 63.6d | 0d | Shuttering Carpenter [78 h]; Scaffolder [26 h]; Finishing Work Crew [52 h] | 2,303.96 | 0 | 0 | 0.0015418111 | 6 | RPI - CONS | Z2 | PW | MECH | 1.3.3.20 | CONS | CONS | ZONE-3 | ROAD-A | MECH | PW |
| CON-Z3-UT-PW-VC-1930 |  | Concrete Supports | 0.8d | 2017-04-03 | 2017-04-04 | CON-Z3-UT-PW-VC-1910 | 63.6d | 0d | Shuttering Carpenter [52 h]; Concrete Mason [52 h]; Common Labor / Helper [52 h] | 3,455.95 | 0 | 0 | 0.000616716 | 6 | RPI - CONS | Z2 | PW | MECH | 1.3.3.20 | CONS | CONS | ZONE-3 | ROAD-A | MECH | PW |
| CON-Z3-UT-PW-VC-1920 |  | Installation of Pipe Connections / Closing of Openings | 3.2d | 2017-04-04 | 2017-04-08 | CON-Z3-UT-PW-VC-1930 | 63.6d | 0d | Shuttering Carpenter [124.8 h]; Concrete Mason [166.4 h]; Plumber [208 h]; Common Labor / Helper [208 h] | 17,279.73 | 0 | 0 | 0.0055505071 | 6 | RPI - CONS | Z2 | PW | MECH | 1.3.3.20 | CONS | CONS | ZONE-3 | ROAD-A | MECH | PW |
| CON-Z3-UT-PW-VC-1940 |  | Damp Proof Coating | 0.8d | 2017-04-08 | 2017-04-09 | CON-Z3-UT-PW-VC-1920, CON-Z3-UT-PW-VC-1910 | 64.4d | 0d | Painter [52 h]; Water Proofing Crew [52 h] | 2,303.96 | 0 | 0 | 0.0015418111 | 6 | RPI - CONS | Z2 | PW | MECH | 1.3.3.20 | CONS | CONS | ZONE-3 | ROAD-A | MECH | PW |
| CON-Z3-UT-PW-VC-5610 |  | Instalaltion of Dismantling Joints | 3d | 2017-04-08 | 2017-04-11 | CON-Z3-UT-PW-VC-1920 | 63.6d | 0d | Common Labor / Helper [195 h]; RTR Pipe Crew [39 h] | 5,759.91 | 0 | 0 | 0.002466885 | 6 | RPI - CONS | Z2 | PW | MECH | 1.3.3.20 | CONS | CONS | ZONE-3 | ROAD-A | MECH | PW |
| CON-Z3-UT-PW-VC-5620 |  | Instalaltion of Pressure Guage | 2.4d | 2017-04-08 | 2017-04-11 | CON-Z3-UT-PW-VC-5610 SS | 63.6d | 0d | Common Labor / Helper [156 h] | 5,759.91 |  |  |  |  |  |  |  |  | 1.3.3.20 | CONS | CONS | ZONE-3 | ROAD-A | MECH | PW |
| CON-Z3-UT-PW-VC-1950 |  | Backfilling & Compaction | 4d | 2017-04-09 | 2017-04-13 | CON-Z3-UT-PW-VC-1940 | 64.4d | 33.6d | Common Labor / Helper [260 h]; Driver - Dump Truck [52 h]; Operator - Bobcat [52 h]; Operator - Roller-Compactor (2~10 Ton) [52 h]; Driver - Water Tanker [52 h]; Operator - JCB [52 h]; Bobcat [56 h]; Plate Compactor [56 h]; Vibrators [56 h]; Water Tanker [56 h]; JCB [56 h] | 5,759.91 | 0 | 0 | 0.0037003381 | 6 | RPI - CONS | Z2 | PW | MECH | 1.3.3.20 | CONS | CONS | ZONE-3 | ROAD-A | MECH | PW |
| CON-Z3-UT-PW-VC-5630 |  | Instalaltion of Butterfly Valves,Gate Valves and Drain Valves | 4d | 2017-04-10 | 2017-04-15 | CON-Z3-UT-PW-VC-5620 SS+1.6d | 63.6d | 32.8d | Concrete Mason [260 h]; RTR Pipe Crew [200 h] | 9,215.85 |  |  |  |  |  |  |  |  | 1.3.3.20 | CONS | CONS | ZONE-3 | ROAD-A | MECH | PW |
| CON-Z3-UT-PW-VC-5640 |  | Installation of Roof Slab, Manhole Cover, Accessories & Finishes | 4d | 2017-05-23 | 2017-05-28 | CON-Z3-UT-PW-VC-5600, CON-Z3-UT-PW-VC-1950, CON-Z3-UT-PW-VC-5630 | 30.8d | 0d | Common Labor / Helper [52 h]; Finishing Work Crew [52 h] | 8,063.87 |  |  |  |  |  |  |  |  | 1.3.3.20 | CONS | CONS | ZONE-3 | ROAD-A | MECH | PW |

Notes:
- CON-Z3-UT-PW-VC-1690: Expenses: (New Expense Item) 5759.91
- CON-Z3-UT-PW-VC-1700: Expenses: (New Expense Item) 3455.95
- CON-Z3-UT-PW-VC-1730: Expenses: (New Expense Item) 5759.91
- CON-Z3-UT-PW-VC-1710: Expenses: (New Expense Item) 5759.91
- CON-Z3-UT-PW-VC-1720: Expenses: (New Expense Item) 5759.91
- CON-Z3-UT-PW-VC-1750: Expenses: (New Expense Item) 11519.8
- CON-Z3-UT-PW-VC-1740: Expenses: (New Expense Item) 5759.91
- CON-Z3-UT-PW-VC-1760: Expenses: (New Expense Item) 11519.8
- CON-Z3-UT-PW-VC-1770: Expenses: (New Expense Item) 2303.96
- CON-Z3-UT-PW-VC-1790: Expenses: (New Expense Item) 3455.95
- CON-Z3-UT-PW-VC-1780: Expenses: (New Expense Item) 17279.7
- CON-Z3-UT-PW-VC-5570: Expenses: (New Expense Item) 5759.91
- CON-Z3-UT-PW-VC-5580: Expenses: (New Expense Item) 5759.91
- CON-Z3-UT-PW-VC-5590: Expenses: (New Expense Item) 9215.85
- CON-Z3-UT-PW-VC-1800: Expenses: (New Expense Item) 2303.96
- CON-Z3-UT-PW-VC-1810: Expenses: (New Expense Item) 5759.91
- CON-Z3-UT-PW-VC-5600: Expenses: (New Expense Item) 8063.87
- CON-Z3-UT-PW-VC-1830: Expenses: (New Expense Item) 5759.91
- CON-Z3-UT-PW-VC-1840: Expenses: (New Expense Item) 3455.95
- CON-Z3-UT-PW-VC-1870: Expenses: (New Expense Item) 5759.91
- CON-Z3-UT-PW-VC-1850: Expenses: (New Expense Item) 5759.91
- CON-Z3-UT-PW-VC-1860: Expenses: (New Expense Item) 5759.91
- CON-Z3-UT-PW-VC-1890: Expenses: (New Expense Item) 11519.8
- CON-Z3-UT-PW-VC-1880: Expenses: (New Expense Item) 5759.91
- CON-Z3-UT-PW-VC-1900: Expenses: (New Expense Item) 11519.8
- CON-Z3-UT-PW-VC-1910: Expenses: (New Expense Item) 2303.96
- CON-Z3-UT-PW-VC-1930: Expenses: (New Expense Item) 3455.95
- CON-Z3-UT-PW-VC-1920: Expenses: (New Expense Item) 17279.7
- CON-Z3-UT-PW-VC-1940: Expenses: (New Expense Item) 2303.96
- CON-Z3-UT-PW-VC-5610: Expenses: (New Expense Item) 5759.91
- CON-Z3-UT-PW-VC-5620: Expenses: (New Expense Item) 5759.91
- CON-Z3-UT-PW-VC-1950: Expenses: (New Expense Item) 5759.91
- CON-Z3-UT-PW-VC-5630: Expenses: (New Expense Item) 9215.85
- CON-Z3-UT-PW-VC-5640: Expenses: (New Expense Item) 8063.87

| ID | WBS | Activity | Duration | Start | Finish | Predecessors | Total float | Free float | Resources | Cost | Activity Wt% | Weight % | Cost Wt | RPI - PHASE | RPI - CONSTRUCTION | RPI - ZONES | RPI - UTILITY NETWORKS | RPI - TYPE OF WORK | RPI_P2 - BOQ ITEMS | RPI_P2 - CONSTRUCTION | RPI_P2 - PHASE | RPI_P2 - ZONES | RPI_P2 - AREAS | RPI_P2 - DISCIPLINE / WORK TYPE | RPI_P2 - UTILITY NETWORK |
| --- | --- | --- | --- | --- | --- | --- | --- | --- | --- | --- | --- | --- | --- | --- | --- | --- | --- | --- | --- | --- | --- | --- | --- | --- | --- |
|  | 14 | **Chamber - New VB Type B2 at Road A/Road B Junction** |  | 2017-03-19 | 2017-06-01 |  |  |  |  |  |  |  |  |  |  |  |  |  |  |  |  |  |  |  |  |
| CON-Z3-UT-PW-VC-1970 |  | Excavation and Compaction | 1.6d | 2017-03-19 | 2017-03-20 | CON-Z3-UT-PW-PL-0210, CON-Z3-UT-PW-PL-0070, CON-Z3-UT-PW-VC-1830 | 66.8d | 0d | Operator - Excavator [26 h] | 5,759.91 | 0 | 0 | 0.0030836221 | 6 | RPI - CONS | Z2 | PW | MECH | 1.3.3.20 | CONS | CONS | ZONE-3 | ROAD-A | MECH | PW |
| CON-Z3-UT-PW-VC-1980 |  | Lean concrete | 0.8d | 2017-03-20 | 2017-03-21 | CON-Z3-UT-PW-VC-1970 | 66.8d | 0d | Concrete Mason [52 h]; Driver - Conc. Transit Mixers [26 h]; Operator - Concrete Pump [26 h] | 3,455.95 | 0 | 0 | 0.0003088871 | 6 | RPI - CONS | Z2 | PW | MECH | 1.3.3.20 | CONS | CONS | ZONE-3 | ROAD-A | MECH | PW |
| CON-Z3-UT-PW-VC-2010 |  | Formwork for Base Slab | 0.8d | 2017-03-21 | 2017-03-22 | CON-Z3-UT-PW-VC-1980 | 66.8d | 0d | Shuttering Carpenter [78 h]; Common Labor / Helper [52 h] | 5,759.91 | 0 | 0 | 0.000308358 | 6 | RPI - CONS | Z2 | PW | MECH | 1.3.3.20 | CONS | CONS | ZONE-3 | ROAD-A | MECH | PW |
| CON-Z3-UT-PW-VC-1990 |  | Fabrication & installation of Rebar for Base Slab | 4d | 2017-03-22 | 2017-03-27 | CON-Z3-UT-PW-VC-2010 | 66.8d | 0d | Steel Fixer [78 h] | 5,759.91 | 0 | 0 | 0.0015418111 | 6 | RPI - CONS | Z2 | PW | MECH | 1.3.3.20 | CONS | CONS | ZONE-3 | ROAD-A | MECH | PW |
| CON-Z3-UT-PW-VC-2000 |  | Fabrication & installation of Rebar for Side walls | 4d | 2017-03-27 | 2017-04-01 | CON-Z3-UT-PW-VC-1990 | 66.8d | 0d | Steel Fixer [78 h] | 5,759.91 | 0 | 0 | 0.0030836221 | 6 | RPI - CONS | Z2 | PW | MECH | 1.3.3.20 | CONS | CONS | ZONE-3 | ROAD-A | MECH | PW |
| CON-Z3-UT-PW-VC-2030 |  | Formwork for side walls | 4d | 2017-03-28 | 2017-04-02 | CON-Z3-UT-PW-VC-2000 SS+0.8d | 66.8d | 0d | Shuttering Carpenter [78 h]; Common Labor / Helper [26 h]; Scaffolder [52 h] | 11,519.82 | 0 | 0 | 0.0015418111 | 6 | RPI - CONS | Z2 | PW | MECH | 1.3.3.20 | CONS | CONS | ZONE-3 | ROAD-A | MECH | PW |
| CON-Z3-UT-PW-VC-2020 |  | Concrete pouring for base slab | 0.8d | 2017-04-02 | 2017-04-02 | CON-Z3-UT-PW-VC-2030 | 66.8d | 0d | Concrete Mason [78 h]; Common Labor / Helper [62.4 h]; Finishing Work Crew [52 h]; Driver - Conc. Transit Mixers [26 h]; Operator - Concrete Pump [26 h] | 5,759.91 | 0 | 0 | 0.0015418111 | 6 | RPI - CONS | Z2 | PW | MECH | 1.3.3.20 | CONS | CONS | ZONE-3 | ROAD-A | MECH | PW |
| CON-Z3-UT-PW-VC-2040 |  | Concrete pouring for Side Wall | 0.8d | 2017-04-03 | 2017-04-03 | CON-Z3-UT-PW-VC-2020 | 66.8d | 0d | Concrete Mason [78 h]; Common Labor / Helper [62.4 h]; Finishing Work Crew [52 h]; Driver - Conc. Transit Mixers [26 h]; Operator - Concrete Pump [26 h] | 11,519.82 | 0 | 0 | 0.0040086961 | 6 | RPI - CONS | Z2 | PW | MECH | 1.3.3.20 | CONS | CONS | ZONE-3 | ROAD-A | MECH | PW |
| CON-Z3-UT-PW-VC-2050 |  | Formwork removal and concrete patching | 1.6d | 2017-04-03 | 2017-04-05 | CON-Z3-UT-PW-VC-2040 | 66.8d | 0d | Shuttering Carpenter [104 h]; Scaffolder [26 h]; Finishing Work Crew [52 h] | 2,303.96 | 0 | 0 | 0.0015418111 | 6 | RPI - CONS | Z2 | PW | MECH | 1.3.3.20 | CONS | CONS | ZONE-3 | ROAD-A | MECH | PW |
| CON-Z3-UT-PW-VC-2070 |  | Concrete Supports | 0.8d | 2017-04-05 | 2017-04-06 | CON-Z3-UT-PW-VC-2050 | 66.8d | 0d | Shuttering Carpenter [31.2 h]; Concrete Mason [31.2 h]; Common Labor / Helper [52 h] | 3,455.95 | 0 | 0 | 0.000616716 | 6 | RPI - CONS | Z2 | PW | MECH | 1.3.3.20 | CONS | CONS | ZONE-3 | ROAD-A | MECH | PW |
| CON-Z3-UT-PW-VC-2060 |  | Installation of Pipe Connections / Closing of Openings | 3.2d | 2017-04-06 | 2017-04-10 | CON-Z3-UT-PW-VC-2070 | 66.8d | 0d | Shuttering Carpenter [166.4 h]; Concrete Mason [166.4 h]; Plumber [166.4 h]; Common Labor / Helper [249.6 h] | 17,279.73 | 0 | 0 | 0.0055505071 | 6 | RPI - CONS | Z2 | PW | MECH | 1.3.3.20 | CONS | CONS | ZONE-3 | ROAD-A | MECH | PW |
| CON-Z3-UT-PW-VC-5650 |  | Instalaltion of Dismantling Joints | 3d | 2017-04-06 | 2017-04-10 | CON-Z3-UT-PW-VC-2060 SS | 69.2d | 0d | Common Labor / Helper [195 h]; RTR Pipe Crew [78 h] | 5,759.91 | 0 | 0 | 0.002466885 | 6 | RPI - CONS | Z2 | PW | MECH | 1.3.3.20 | CONS | CONS | ZONE-3 | ROAD-A | MECH | PW |
| CON-Z3-UT-PW-VC-5660 |  | Instalaltion of Pressure Guage | 2.4d | 2017-04-06 | 2017-04-09 | CON-Z3-UT-PW-VC-5650 SS | 69.2d | 0d | Common Labor / Helper [187.2 h] | 5,759.91 |  |  |  |  |  |  |  |  | 1.3.3.20 | CONS | CONS | ZONE-3 | ROAD-A | MECH | PW |
| CON-Z3-UT-PW-VC-5670 |  | Instalaltion of Gate Valves and Drain Valves | 4d | 2017-04-08 | 2017-04-12 | CON-Z3-UT-PW-VC-5660 SS+1.6d | 69.2d | 38.4d | Common Labor / Helper [260 h]; RTR Pipe Crew [52 h] | 9,215.85 |  |  |  |  |  |  |  |  | 1.3.3.20 | CONS | CONS | ZONE-3 | ROAD-A | MECH | PW |
| CON-Z3-UT-PW-VC-2080 |  | Damp Proof Coating | 0.8d | 2017-04-10 | 2017-04-11 | CON-Z3-UT-PW-VC-2060, CON-Z3-UT-PW-VC-2050 | 66.8d | 0d | Painter [52 h]; Water Proofing Crew [52 h] | 2,303.96 | 0 | 0 | 0.0015418111 | 6 | RPI - CONS | Z2 | PW | MECH | 1.3.3.20 | CONS | CONS | ZONE-3 | ROAD-A | MECH | PW |
| CON-Z3-UT-PW-VC-2090 |  | Backfilling & Compaction | 4d | 2017-04-11 | 2017-04-16 | CON-Z3-UT-PW-VC-2080 | 66.8d | 36d | Common Labor / Helper [312 h]; Driver - Dump Truck [52 h]; Operator - Bobcat [52 h]; Operator - Roller-Compactor (2~10 Ton) [52 h]; Driver - Water Tanker [52 h]; Operator - JCB [52 h]; Bobcat [56 h]; Plate Compactor [56 h]; Vibrators [56 h]; Water Tanker [56 h]; JCB [56 h] | 5,759.91 | 0 | 0 | 0.0037003381 | 6 | RPI - CONS | Z2 | PW | MECH | 1.3.3.20 | CONS | CONS | ZONE-3 | ROAD-A | MECH | PW |
| CON-Z3-UT-PW-VC-5680 |  | Installation of Roof Slab, Manhole Cover, Accessories & Finishes | 4d | 2017-05-28 | 2017-06-01 | CON-Z3-UT-PW-VC-5670, CON-Z3-UT-PW-VC-5640, CON-Z3-UT-PW-VC-2090 | 30.8d | 0d | Common Labor / Helper [52 h]; Finishing Work Crew [52 h] | 8,063.87 |  |  |  |  |  |  |  |  | 1.3.3.20 | CONS | CONS | ZONE-3 | ROAD-A | MECH | PW |
|  | 15 | **Air Valve Chamber Type D at Road 4/Road 2 Junction** |  | 2017-03-20 | 2017-06-01 |  |  |  |  |  |  |  |  |  |  |  |  |  |  |  |  |  |  |  |  |
| CON-Z3-UT-PW-VC-3010 |  | Excavation and Compaction | 1.6d | 2017-03-20 | 2017-03-22 | CON-Z3-UT-PW-VC-1970 | 68.8d | 0d | Operator - Excavator [26 h] | 5,759.91 | 0 | 0 | 0.0030836221 | 6 | RPI - CONS | Z2 | PW | MECH | 1.3.3.20 | CONS | CONS | ZONE-3 | ROAD-2 | MECH | PW |
| CON-Z3-UT-PW-VC-3020 |  | Lean concrete | 0.8d | 2017-03-22 | 2017-03-23 | CON-Z3-UT-PW-VC-3010 | 68.8d | 0d | Concrete Mason [52 h]; Driver - Conc. Transit Mixers [26 h]; Operator - Concrete Pump [26 h] | 3,455.95 | 0 | 0 | 0.0003088871 | 6 | RPI - CONS | Z2 | PW | MECH | 1.3.3.20 | CONS | CONS | ZONE-3 | ROAD-2 | MECH | PW |
| CON-Z3-UT-PW-VC-3050 |  | Formwork for Base Slab | 0.8d | 2017-03-23 | 2017-03-23 | CON-Z3-UT-PW-VC-3020 | 68.8d | 0d | Shuttering Carpenter [78 h]; Common Labor / Helper [52 h] | 5,759.91 | 0 | 0 | 0.000308358 | 6 | RPI - CONS | Z2 | PW | MECH | 1.3.3.20 | CONS | CONS | ZONE-3 | ROAD-2 | MECH | PW |
| CON-Z3-UT-PW-VC-3030 |  | Fabrication & installation of Rebar for Base Slab | 4d | 2017-03-25 | 2017-03-28 | CON-Z3-UT-PW-VC-3050 | 68.8d | 0d | Steel Fixer [78 h] | 5,759.91 | 0 | 0 | 0.0015418111 | 6 | RPI - CONS | Z2 | PW | MECH | 1.3.3.20 | CONS | CONS | ZONE-3 | ROAD-2 | MECH | PW |
| CON-Z3-UT-PW-VC-3040 |  | Fabrication & installation of Rebar for Side walls | 4d | 2017-03-29 | 2017-04-02 | CON-Z3-UT-PW-VC-3030 | 68.8d | 0d | Steel Fixer [78 h] | 5,759.91 | 0 | 0 | 0.0030836221 | 6 | RPI - CONS | Z2 | PW | MECH | 1.3.3.20 | CONS | CONS | ZONE-3 | ROAD-2 | MECH | PW |
| CON-Z3-UT-PW-VC-3070 |  | Formwork for side walls | 4d | 2017-03-29 | 2017-04-03 | CON-Z3-UT-PW-VC-3040 SS+0.8d | 68.8d | 0d | Shuttering Carpenter [78 h]; Common Labor / Helper [26 h]; Scaffolder [52 h] | 11,519.82 | 0 | 0 | 0.0015418111 | 6 | RPI - CONS | Z2 | PW | MECH | 1.3.3.20 | CONS | CONS | ZONE-3 | ROAD-2 | MECH | PW |
| CON-Z3-UT-PW-VC-3060 |  | Concrete pouring for base slab | 0.8d | 2017-04-03 | 2017-04-04 | CON-Z3-UT-PW-VC-3070 | 68.8d | 0d | Concrete Mason [78 h]; Common Labor / Helper [62.4 h]; Finishing Work Crew [52 h]; Driver - Conc. Transit Mixers [26 h]; Operator - Concrete Pump [26 h] | 5,759.91 | 0 | 0 | 0.0015418111 | 6 | RPI - CONS | Z2 | PW | MECH | 1.3.3.20 | CONS | CONS | ZONE-3 | ROAD-2 | MECH | PW |
| CON-Z3-UT-PW-VC-3080 |  | Concrete pouring for Side Wall | 0.8d | 2017-04-04 | 2017-04-05 | CON-Z3-UT-PW-VC-3060 | 68.8d | 0d | Concrete Mason [78 h]; Common Labor / Helper [62.4 h]; Finishing Work Crew [52 h]; Driver - Conc. Transit Mixers [26 h]; Operator - Concrete Pump [26 h] | 11,519.82 | 0 | 0 | 0.0040086961 | 6 | RPI - CONS | Z2 | PW | MECH | 1.3.3.20 | CONS | CONS | ZONE-3 | ROAD-2 | MECH | PW |
| CON-Z3-UT-PW-VC-3090 |  | Formwork removal and concrete patching | 1.6d | 2017-04-05 | 2017-04-06 | CON-Z3-UT-PW-VC-3080 | 68.8d | 0d | Shuttering Carpenter [78 h]; Scaffolder [26 h]; Finishing Work Crew [52 h] | 2,303.96 | 0 | 0 | 0.0015418111 | 6 | RPI - CONS | Z2 | PW | MECH | 1.3.3.20 | CONS | CONS | ZONE-3 | ROAD-2 | MECH | PW |
| CON-Z3-UT-PW-VC-4010 |  | Concrete Supports | 0.8d | 2017-04-08 | 2017-04-08 | CON-Z3-UT-PW-VC-3090 | 68.8d | 0d | Shuttering Carpenter [52 h]; Concrete Mason [62.4 h]; Common Labor / Helper [62.4 h] | 3,455.95 | 0 | 0 | 0.000616716 | 6 | RPI - CONS | Z2 | PW | MECH | 1.3.3.20 | CONS | CONS | ZONE-3 | ROAD-2 | MECH | PW |
| CON-Z3-UT-PW-VC-4000 |  | Installation of Pipe Connections / Closing of Openings | 3.2d | 2017-04-08 | 2017-04-11 | CON-Z3-UT-PW-VC-4010 | 68.8d | 0d | Shuttering Carpenter [166.4 h]; Concrete Mason [166.4 h]; Plumber [208 h]; Common Labor / Helper [249.6 h] | 17,279.73 | 0 | 0 | 0.0055505071 | 6 | RPI - CONS | Z2 | PW | MECH | 1.3.3.20 | CONS | CONS | ZONE-3 | ROAD-2 | MECH | PW |
| CON-Z3-UT-PW-VC-5690 |  | Instalaltion of Dismantling Joints | 3d | 2017-04-08 | 2017-04-11 | CON-Z3-UT-PW-VC-4000 SS | 68.8d | 0d | Common Labor / Helper [234 h]; RTR Pipe Crew [39 h] | 8,063.87 | 0 | 0 | 0.0037003381 | 6 | RPI - CONS | Z2 | PW | MECH | 1.3.3.20 | CONS | CONS | ZONE-3 | ROAD-2 | MECH | PW |
| CON-Z3-UT-PW-VC-5700 |  | Instalaltion of Gate Valves and Pressure Releasing Valves | 2.4d | 2017-04-10 | 2017-04-13 | CON-Z3-UT-PW-VC-5690 SS+2d | 68.8d | 38d | Common Labor / Helper [187.2 h]; RTR Pipe Crew [31.2 h] | 11,519.82 |  |  |  |  |  |  |  |  | 1.3.3.20 | CONS | CONS | ZONE-3 | ROAD-2 | MECH | PW |
| CON-Z3-UT-PW-VC-4020 |  | Damp Proof Coating | 0.8d | 2017-04-12 | 2017-04-12 | CON-Z3-UT-PW-VC-3090, CON-Z3-UT-PW-VC-4000 | 69.2d | 0d | Painter [52 h]; Water Proofing Crew [52 h] | 2,303.96 | 0 | 0 | 0.0015418111 | 6 | RPI - CONS | Z2 | PW | MECH | 1.3.3.20 | CONS | CONS | ZONE-3 | ROAD-2 | MECH | PW |
| CON-Z3-UT-PW-VC-4030 |  | Backfilling & Compaction | 4d | 2017-04-12 | 2017-04-17 | CON-Z3-UT-PW-VC-4020 | 69.2d | 38.4d | Common Labor / Helper [312 h]; Driver - Dump Truck [52 h]; Operator - Bobcat [52 h]; Operator - Roller-Compactor (2~10 Ton) [52 h]; Driver - Water Tanker [52 h]; Operator - JCB [52 h]; Bobcat [56 h]; Plate Compactor [56 h]; Vibrators [56 h]; Water Tanker [56 h]; JCB [56 h] | 5,759.91 | 0 | 0 | 0.0037003381 | 6 | RPI - CONS | Z2 | PW | MECH | 1.3.3.20 | CONS | CONS | ZONE-3 | ROAD-2 | MECH | PW |
| CON-Z3-UT-PW-VC-5710 |  | Installation of Roof Slab, Manhole Cover, Accessories & Finishes | 4d | 2017-05-28 | 2017-06-01 | CON-Z3-UT-PW-VC-4030 SS, CON-Z3-UT-PW-VC-5680 SS, CON-Z3-UT-PW-VC-5700 | 30.8d | 0d | Common Labor / Helper [52 h]; Finishing Work Crew [52 h] | 9,215.85 |  |  |  |  |  |  |  |  | 1.3.3.20 | CONS | CONS | ZONE-3 | ROAD-2 | MECH | PW |

Notes:
- CON-Z3-UT-PW-VC-1970: Expenses: (New Expense Item) 5759.91
- CON-Z3-UT-PW-VC-1980: Expenses: (New Expense Item) 3455.95
- CON-Z3-UT-PW-VC-2010: Expenses: (New Expense Item) 5759.91
- CON-Z3-UT-PW-VC-1990: Expenses: (New Expense Item) 5759.91
- CON-Z3-UT-PW-VC-2000: Expenses: (New Expense Item) 5759.91
- CON-Z3-UT-PW-VC-2030: Expenses: (New Expense Item) 11519.8
- CON-Z3-UT-PW-VC-2020: Expenses: (New Expense Item) 5759.91
- CON-Z3-UT-PW-VC-2040: Expenses: (New Expense Item) 11519.8
- CON-Z3-UT-PW-VC-2050: Expenses: (New Expense Item) 2303.96
- CON-Z3-UT-PW-VC-2070: Expenses: (New Expense Item) 3455.95
- CON-Z3-UT-PW-VC-2060: Expenses: (New Expense Item) 17279.7
- CON-Z3-UT-PW-VC-5650: Expenses: (New Expense Item) 5759.91
- CON-Z3-UT-PW-VC-5660: Expenses: (New Expense Item) 5759.91
- CON-Z3-UT-PW-VC-5670: Expenses: (New Expense Item) 9215.85
- CON-Z3-UT-PW-VC-2080: Expenses: (New Expense Item) 2303.96
- CON-Z3-UT-PW-VC-2090: Expenses: (New Expense Item) 5759.91
- CON-Z3-UT-PW-VC-5680: Expenses: (New Expense Item) 8063.87
- CON-Z3-UT-PW-VC-3010: Expenses: (New Expense Item) 5759.91
- CON-Z3-UT-PW-VC-3020: Expenses: (New Expense Item) 3455.95
- CON-Z3-UT-PW-VC-3050: Expenses: (New Expense Item) 5759.91
- CON-Z3-UT-PW-VC-3030: Expenses: (New Expense Item) 5759.91
- CON-Z3-UT-PW-VC-3040: Expenses: (New Expense Item) 5759.91
- CON-Z3-UT-PW-VC-3070: Expenses: (New Expense Item) 11519.8
- CON-Z3-UT-PW-VC-3060: Expenses: (New Expense Item) 5759.91
- CON-Z3-UT-PW-VC-3080: Expenses: (New Expense Item) 11519.8
- CON-Z3-UT-PW-VC-3090: Expenses: (New Expense Item) 2303.96
- CON-Z3-UT-PW-VC-4010: Expenses: (New Expense Item) 3455.95
- CON-Z3-UT-PW-VC-4000: Expenses: (New Expense Item) 17279.7
- CON-Z3-UT-PW-VC-5690: Expenses: (New Expense Item) 8063.87
- CON-Z3-UT-PW-VC-5700: Expenses: (New Expense Item) 11519.8
- CON-Z3-UT-PW-VC-4020: Expenses: (New Expense Item) 2303.96
- CON-Z3-UT-PW-VC-4030: Expenses: (New Expense Item) 5759.91
- CON-Z3-UT-PW-VC-5710: Expenses: (New Expense Item) 9215.85

| ID | WBS | Activity | Duration | Start | Finish | Predecessors | Total float | Free float | Resources | Cost | RPI_P2 - BOQ ITEMS | RPI_P2 - CONSTRUCTION | RPI_P2 - PHASE | RPI_P2 - ZONES | RPI_P2 - DISCIPLINE / WORK TYPE | RPI_P2 - UTILITY NETWORK | RPI_P2 - AREAS |
| --- | --- | --- | --- | --- | --- | --- | --- | --- | --- | --- | --- | --- | --- | --- | --- | --- | --- |
|  | 16 | **Interfaces and Tie in Connections With Existing KAUST Utilities** |  | 2017-05-16 | 2017-06-04 |  |  |  |  |  |  |  |  |  |  |  |  |
| CON-SZ3-SS-TIE-40 |  | Potable Water Line to LS#10 & LS#11 Interface With SS#4, SS#5 and AEB | 7d | 2017-05-16 | 2017-05-24 | CON-Z3-UT-PW-PL-790 | 38.6d | 0d | Shuttering Carpenter [26 h]; Common Labor / Helper [52 h]; RTR Pipe Crew [26 h] | 46,079.27 | 1.3.3.20 | CONS | CONS | ZONE-3 | MECH | PW |  |
| CON-SZ3-SS-TIE-50 |  | Main Potable Water Line interface With Existing KAUST Potable Line in Zone 3 | 7d | 2017-05-16 | 2017-05-24 | CON-SZ3-SS-TIE-40 SS | 38.6d | 7.8d | Shuttering Carpenter [26 h]; Common Labor / Helper [52 h]; RTR Pipe Crew [26 h] | 34,559.45 | 1.3.3.20 | CONS | CONS | ZONE-3 | MECH | PW |  |
| CON-SZ3-SS-TIE-60 |  | Extension of Existing RO Plant interface with pipe at TIE-IN VB#3 near CUP Area | 6d | 2017-05-28 | 2017-06-04 | CON-Z3-UT-PW-VC-5710 SS, CON-SZ3-SS-TIE-50 SS+2d | 30.8d | 0d | Shuttering Carpenter [26 h]; Common Labor / Helper [52 h]; RTR Pipe Crew [26 h] | 34,559.45 | 1.3.3.20 | CONS | CONS | ZONE-3 | MECH | PW |  |
|  | 3 | **Sea Water System** |  | 2016-10-12 | 2017-08-03 |  |  |  |  |  |  |  |  |  |  |  |  |
|  | 8 | **Sea Water Lines** |  | 2016-10-12 | 2017-05-31 |  |  |  |  |  |  |  |  |  |  |  |  |
|  | 6 | **Sea Water Line - RTR 500mm dia at Road 3 = 1968.52 Lm** |  | 2016-10-12 | 2016-12-21 |  |  |  |  |  |  |  |  |  |  |  |  |
| CON-Z3-UTIL-SEA-030 |  | Installation of Thurst Blocks of already installed Pipe line | 20d | 2016-10-12 | 2016-11-05 | CON-CON-CON-CON-0010 FS+45d, CON-Z3-UT-PW-PL-0120 SS | 42.8d | 0d | Steel Fixer [1300 h]; Shuttering Carpenter [1300 h]; Concrete Mason [1300 h]; Common Labor / Helper [2600 h]; Driver - Conc. Transit Mixers [260 h]; Operator - Concrete Pump [260 h]; Concrete Transit Mixers [280 h]; Concrete Pump [280 h] | 19,252.32 | 1.3.3.30 | CONS | CONS | ZONE-3 | MECH | SEA-W | ROAD-3 |
| CON-Z3-UTIL-SEA-040 |  | Testing and Precomissioning | 40d | 2016-11-05 | 2016-12-21 | CON-Z3-UTIL-SEA-030 | 47.8d | 5d | Plumber [2600 h]; Common Labor / Helper [200 h]; RTR Pipe Crew [1040 h]; Driver - Water Tanker [200 h]; Water Tanker [200 h] | 77,009.27 | 1.3.3.30 | CONS | CONS | ZONE-3 | MECH | SEA-W | ROAD-3 |
|  | 7 | **Sea Water Line - RTR 600mm dia at Road 3 = 1968.52 Lm** |  | 2016-10-18 | 2016-12-27 |  |  |  |  |  |  |  |  |  |  |  |  |
| CON-Z3-UTIL-SEA-050 |  | Installation of Thurst Blocks of already installed Pipe line | 20d | 2016-10-18 | 2016-11-10 | CON-Z3-UTIL-SEA-030 SS+5d | 42.8d | 0d | Steel Fixer [1600 h]; Shuttering Carpenter [1600 h]; Concrete Mason [1600 h]; Common Labor / Helper [2600 h]; Driver - Conc. Transit Mixers [260 h]; Operator - Concrete Pump [260 h]; Concrete Transit Mixers [280 h]; Concrete Pump [280 h] | 19,252.32 | 1.3.3.30 | CONS | CONS | ZONE-3 | MECH | SEA-W | ROAD-3 |
| CON-Z3-UTIL-SEA-060 |  | Testing and Precomissioning | 40d | 2016-11-10 | 2016-12-27 | CON-Z3-UTIL-SEA-050, CON-Z3-UTIL-SEA-040 SS | 42.8d | 0d | Plumber [2600 h]; Common Labor / Helper [2080 h]; RTR Pipe Crew [1040 h]; Driver - Water Tanker [200 h]; Water Tanker [200 h] | 77,009.27 | 1.3.3.30 | CONS | CONS | ZONE-3 | MECH | SEA-W | ROAD-3 |
|  | 1 | **Sea Water Line - RTR 750mm dia at Road 5 = 16.84 Lm** |  | 2016-11-27 | 2016-12-27 |  |  |  |  |  |  |  |  |  |  |  |  |
| CON-Z3-UT-SEA-PL-180 |  | Excavation of Trench | 0.8d | 2016-11-27 | 2016-11-27 | CON-CON-CON-CON-0010 FS+90d | 30.8d | 0d | Common Labor / Helper [4 h]; Operator - Excavator [4 h]; Driver - Dump Truck [4 h]; Operator - JCB [4 h]; Excavator [4 h]; Dump Truck [4 h]; JCB [4 h] | 3,937.97 | 1.3.3.30 | CONS | CONS | ZONE-3 | MECH | SEA-W | ROAD-5 |
| CON-Z3-UT-SEA-PL-190 |  | Compaction and Sanbedding | 0.8d | 2016-11-30 | 2016-12-01 | CON-Z3-UT-SEA-PL-180 SS+3.2d | 86.2d | 10d | Common Labor / Helper [39 h]; Driver - Dump Truck [13 h]; Operator - Roller-Compactor (2~10 Ton) [13 h]; Driver - Water Tanker [13 h]; Operator - JCB [13 h]; Dump Truck [14 h]; Roller-Compactor (2~10 Ton) [14 h]; Plate Compactor [14 h]; Vibrators [14 h]; Water Tanker [14 h] | 2,625.32 | 1.3.3.30 | CONS | CONS | ZONE-3 | MECH | SEA-W | ROAD-5 |
| CON-Z3-UT-SEA-PL-200 |  | Pipe Laying | 0.8d | 2016-12-14 | 2016-12-15 | CON-Z3-UT-SEA-PL-190 SS+2.4d, PR-Z3-UT-PW-132-0080 | 76.2d | 0d | Plumber [62.4 h]; Common Labor / Helper [52 h]; RTR Pipe Crew [20.8 h]; Operator - Mobile Crane [10.4 h]; Driver - Flat Bed Trailer [10.4 h]; Mobile Crane ( 25-60 Ton) [11.2 h]; Flat Bed Trailer [11.2 h] | 7,875.95 | 1.3.3.30 | CONS | CONS | ZONE-3 | MECH | SEA-W | ROAD-5 |
| CON-Z3-UT-SEA-PL-210 |  | Installation of Thurst Block | 1d | 2016-12-19 | 2016-12-20 | CON-Z3-UT-SEA-PL-200 SS+4d | 76.2d | 0d | Steel Fixer [26 h]; Shuttering Carpenter [52 h]; Concrete Mason [52 h]; Common Labor / Helper [52 h]; Driver - Conc. Transit Mixers [26 h]; Operator - Concrete Pump [26 h]; Concrete Transit Mixers [28 h]; Concrete Pump [28 h] | 2,625.32 | 1.3.3.30 | CONS | CONS | ZONE-3 | MECH | SEA-W | ROAD-5 |
| CON-Z3-UT-SEA-PL-220 |  | Backfilling | 2d | 2016-12-20 | 2016-12-22 | CON-Z3-UT-SEA-PL-200, CON-Z3-UT-SEA-PL-210, PR-Z3-CW-CW-26-0080 | 76.2d | 2.8d | Common Labor / Helper [156 h]; Operator - Loader [26 h]; Driver - Dump Truck [26 h]; Operator - Bobcat [26 h]; Operator - Roller-Compactor (2~10 Ton) [26 h]; Driver - Water Tanker [26 h]; Operator - JCB [26 h]; Loader [28 h]; Dump Truck [28 h]; Bobcat [28 h]; Roller-Compactor (2~10 Ton) [28 h]; Plate Compactor [28 h]; Vibrators [28 h]; Water Tanker [28 h]; JCB [28 h] | 3,937.97 | 1.3.3.30 | CONS | CONS | ZONE-3 | MECH | SEA-W | ROAD-5 |
| CON-Z3-UT-SEA-PL-230 |  | Testing and Precommissioning | 0.8d | 2016-12-27 | 2016-12-27 | CON-Z3-UT-SEA-PL-220, CON-Z3-UTIL-SEA-060 | 107d | 23.6d | Plumber [52 h]; Common Labor / Helper [52 h]; RTR Pipe Crew [52 h]; Driver - Water Tanker [26 h]; Water Tanker [28 h] | 5,250.63 | 1.3.3.30 | CONS | CONS | ZONE-3 | MECH | SEA-W | ROAD-5 |
|  | 2 | **Sea Water Line - RTR 600mm dia at Road 5 = 540.83 Lm** |  | 2016-11-28 | 2017-02-02 |  |  |  |  |  |  |  |  |  |  |  |  |
| CON-Z3-UT-SEA-PL-240 |  | Excavation of Trench | 4d | 2016-11-28 | 2016-12-01 | CON-Z3-UT-SEA-PL-180 | 30.8d | 0d | Common Labor / Helper [26 h]; Operator - Excavator [26 h]; Driver - Dump Truck [26 h]; Operator - JCB [26 h]; Excavator [28 h]; Dump Truck [28 h] | 32,816.45 | 1.3.3.30 | CONS | CONS | ZONE-3 | MECH | SEA-W | ROAD-5 |
| CON-Z3-UT-SEA-PL-250 |  | Compaction and Sanbedding | 4d | 2016-12-01 | 2016-12-06 | CON-Z3-UT-SEA-PL-240 SS+3.2d | 73.4d | 0d | Common Labor / Helper [260 h]; Driver - Dump Truck [52 h]; Operator - Roller-Compactor (2~10 Ton) [52 h]; Driver - Water Tanker [52 h]; Operator - JCB [52 h]; JCB [56 h]; Roller-Compactor (2~10 Ton) [56 h]; Dump Truck [56 h]; Water Tanker [56 h] | 21,877.63 | 1.3.3.30 | CONS | CONS | ZONE-3 | MECH | SEA-W | ROAD-5 |
| CON-Z3-UT-SEA-PL-260 |  | Pipe Laying | 15d | 2016-12-04 | 2016-12-21 | CON-Z3-UT-SEA-PL-250 SS+2.4d | 73.4d | 0d | Plumber [52 h]; Common Labor / Helper [78 h]; RTR Pipe Crew [52 h]; Operator - Mobile Crane [26 h]; Driver - Flat Bed Trailer [26 h]; Mobile Crane ( 25-60 Ton) [28 h]; Flat Bed Trailer [28 h] | 65,632.9 | 1.3.3.30 | CONS | CONS | ZONE-3 | MECH | SEA-W | ROAD-5 |
| CON-Z3-UT-SEA-PL-270 |  | Installation of Thurst Block | 15d | 2016-12-08 | 2016-12-26 | CON-Z3-UT-SEA-PL-260 SS+4d | 73.4d | 0d | Steel Fixer [26 h]; Shuttering Carpenter [52 h]; Concrete Mason [52 h]; Common Labor / Helper [52 h]; Driver - Conc. Transit Mixers [26 h]; Operator - Concrete Pump [26 h]; Concrete Transit Mixers [28 h]; Concrete Pump [28 h] | 21,877.63 | 1.3.3.30 | CONS | CONS | ZONE-3 | MECH | SEA-W | ROAD-5 |
| CON-Z3-UT-SEA-PL-280 |  | Backfilling | 25d | 2016-12-26 | 2017-01-24 | CON-Z3-UT-SEA-PL-270, CON-Z3-UT-SEA-PL-220, CON-Z3-UT-SEA-PL-260 | 73.4d | 0d | Common Labor / Helper [104 h]; Operator - Loader [26 h]; Driver - Dump Truck [26 h]; Operator - Bobcat [26 h]; Operator - Asphalt Compactor / Roller [26 h]; Operator - Roller-Compactor (2~10 Ton) [26 h]; Driver - Water Tanker [26 h]; Operator - JCB [26 h]; Loader [28 h]; Dump Truck [28 h]; Bobcat [28 h]; Roller-Compactor (2~10 Ton) [28 h]; Plate Compactor [28 h]; Vibrators [28 h]; Water Tanker [28 h]; JCB [28 h] | 32,816.45 | 1.3.3.30 | CONS | CONS | ZONE-3 | MECH | SEA-W | ROAD-5 |
| CON-Z3-UT-SEA-PL-290 |  | Testing and Precommissioning | 8d | 2017-01-24 | 2017-02-02 | CON-Z3-UT-SEA-PL-280, CON-Z3-UT-SEA-PL-230 | 83.4d | 10d | Plumber [208 h]; Common Labor / Helper [208 h]; RTR Pipe Crew [104 h]; Driver - Water Tanker [104 h]; Water Tanker [112 h] | 43,755.27 | 1.3.3.30 | CONS | CONS | ZONE-3 | MECH | SEA-W | ROAD-5 |

Notes:
- CON-SZ3-SS-TIE-40: Expenses: (New Expense Item) 46079.3
- CON-SZ3-SS-TIE-50: Expenses: (New Expense Item) 34559.4
- CON-SZ3-SS-TIE-60: Expenses: (New Expense Item) 34559.4
- CON-Z3-UTIL-SEA-030: Expenses: (New Expense Item) 19252.3
- CON-Z3-UTIL-SEA-040: Expenses: (New Expense Item) 77009.3
- CON-Z3-UTIL-SEA-050: Expenses: (New Expense Item) 19252.3
- CON-Z3-UTIL-SEA-060: Expenses: (New Expense Item) 77009.3
- CON-Z3-UT-SEA-PL-180: Expenses: (New Expense Item) 3937.97
- CON-Z3-UT-SEA-PL-190: Expenses: (New Expense Item) 2625.32
- CON-Z3-UT-SEA-PL-200: Expenses: (New Expense Item) 7875.95
- CON-Z3-UT-SEA-PL-210: Expenses: (New Expense Item) 2625.32
- CON-Z3-UT-SEA-PL-220: Expenses: (New Expense Item) 3937.97
- CON-Z3-UT-SEA-PL-230: Expenses: (New Expense Item) 5250.63
- CON-Z3-UT-SEA-PL-240: Expenses: (New Expense Item) 32816.4
- CON-Z3-UT-SEA-PL-250: Expenses: (New Expense Item) 21877.6
- CON-Z3-UT-SEA-PL-260: Expenses: (New Expense Item) 65632.9
- CON-Z3-UT-SEA-PL-270: Expenses: (New Expense Item) 21877.6
- CON-Z3-UT-SEA-PL-280: Expenses: (New Expense Item) 32816.4
- CON-Z3-UT-SEA-PL-290: Expenses: (New Expense Item) 43755.3

| ID | WBS | Activity | Duration | Start | Finish | Predecessors | Total float | Free float | Resources | Cost | RPI_P2 - BOQ ITEMS | RPI_P2 - CONSTRUCTION | RPI_P2 - PHASE | RPI_P2 - ZONES | RPI_P2 - AREAS | RPI_P2 - DISCIPLINE / WORK TYPE | RPI_P2 - UTILITY NETWORK | Activity Wt% | Weight % | Cost Wt | RPI - PHASE | RPI - CONSTRUCTION | RPI - ZONES | RPI - UTILITY NETWORKS | RPI - TYPE OF WORK |
| --- | --- | --- | --- | --- | --- | --- | --- | --- | --- | --- | --- | --- | --- | --- | --- | --- | --- | --- | --- | --- | --- | --- | --- | --- | --- |
|  | 3 | **Sea Water Line - RTR 500mm dia at Road 5 = 523.99 Lm** |  | 2016-12-03 | 2017-02-23 |  |  |  |  |  |  |  |  |  |  |  |  |  |  |  |  |  |  |  |  |
| CON-Z3-UT-SEA-PL-300 |  | Excavation of Trench | 4d | 2016-12-03 | 2016-12-06 | CON-Z3-UT-SEA-PL-240 | 30.8d | 0d | Common Labor / Helper [156 h]; Operator - Excavator [52 h]; Driver - Dump Truck [52 h]; Operator - JCB [52 h]; Excavator [56 h]; Dump Truck [56 h]; JCB [56 h] | 32,816.45 | 1.3.3.30 | CONS | CONS | ZONE-3 | ROAD-5 | MECH | SEA-W |  |  |  |  |  |  |  |  |
| CON-Z3-UT-SEA-PL-310 |  | Compaction and Sanbedding | 4d | 2016-12-06 | 2016-12-11 | CON-Z3-UT-SEA-PL-300 SS+3.2d | 99.4d | 0d | Operator - JCB [52 h]; Dump Truck [56 h]; JCB [56 h]; Roller-Compactor (2~10 Ton) [56 h]; Water Tanker [56 h]; Common Labor / Helper [156 h]; Driver - Dump Truck [52 h]; Operator - Roller-Compactor (2~10 Ton) [52 h]; Driver - Water Tanker [52 h] | 21,877.63 | 1.3.3.30 | CONS | CONS | ZONE-3 | ROAD-5 | MECH | SEA-W |  |  |  |  |  |  |  |  |
| CON-Z3-UT-SEA-PL-320 |  | Pipe Laying | 13d | 2016-12-08 | 2016-12-24 | CON-Z3-UT-SEA-PL-310 SS+2.4d | 99.4d | 0d | Plumber [676 h]; Common Labor / Helper [507 h]; RTR Pipe Crew [338 h]; Operator - Mobile Crane [169 h]; Driver - Flat Bed Trailer [169 h]; Mobile Crane ( 25-60 Ton) [182 h]; Flat Bed Trailer [182 h] | 65,632.9 | 1.3.3.30 | CONS | CONS | ZONE-3 | ROAD-5 | MECH | SEA-W |  |  |  |  |  |  |  |  |
| CON-Z3-UT-SEA-PL-330 |  | Installation of Thurst Block | 10d | 2016-12-13 | 2016-12-25 | CON-Z3-UT-SEA-PL-320 SS+4d | 99.4d | 26d | Steel Fixer [26 h]; Shuttering Carpenter [52 h]; Concrete Mason [52 h]; Common Labor / Helper [52 h]; Driver - Conc. Transit Mixers [26 h]; Operator - Concrete Pump [26 h]; Concrete Transit Mixers [28 h]; Concrete Pump [28 h] | 21,877.63 | 1.3.3.30 | CONS | CONS | ZONE-3 | ROAD-5 | MECH | SEA-W |  |  |  |  |  |  |  |  |
| CON-Z3-UT-SEA-PL-340 |  | Backfilling | 18d | 2017-01-24 | 2017-02-14 | CON-Z3-UT-SEA-PL-280, CON-Z3-UT-SEA-PL-320, CON-Z3-UT-SEA-PL-330 | 73.4d | 0d | Common Labor / Helper [468 h]; Operator - Loader [117 h]; Driver - Dump Truck [117 h]; Operator - Bobcat [117 h]; Operator - Roller-Compactor (2~10 Ton) [117 h]; Driver - Water Tanker [117 h]; Operator - JCB [117 h]; Loader [126 h]; Dump Truck [126 h]; Bobcat [252 h]; Roller-Compactor (2~10 Ton) [126 h]; Plate Compactor [126 h]; Vibrators [126 h]; Water Tanker [126 h]; JCB [126 h] | 32,816.45 | 1.3.3.30 | CONS | CONS | ZONE-3 | ROAD-5 | MECH | SEA-W |  |  |  |  |  |  |  |  |
| CON-Z3-UT-SEA-PL-350 |  | Testing and Precommissioning | 8d | 2017-02-14 | 2017-02-23 | CON-Z3-UT-SEA-PL-340, CON-Z3-UT-SEA-PL-290 | 73.4d | 0d | Plumber [520 h]; Common Labor / Helper [416 h]; RTR Pipe Crew [52 h]; Driver - Water Tanker [80 h]; Water Tanker [112 h] | 43,755.27 | 1.3.3.30 | CONS | CONS | ZONE-3 | ROAD-5 | MECH | SEA-W |  |  |  |  |  |  |  |  |
|  | 4 | **Sea Water Line - RTR 500mm dia at Road 5 = 473.69 Lm** |  | 2016-12-13 | 2017-05-31 |  |  |  |  |  |  |  |  |  |  |  |  |  |  |  |  |  |  |  |  |
| CON-Z3-UT-SEA-PL-360 |  | Excavation of Trench | 3.2d | 2016-12-13 | 2016-12-17 | CON-Z3-UT-SEA-PL-300 FS+5d | 30.8d | 0d | Common Labor / Helper [124.8 h]; Operator - Excavator [41.6 h]; Driver - Dump Truck [41.6 h]; Operator - JCB [41.6 h]; Excavator [44.8 h]; Dump Truck [44.8 h]; JCB [44.8 h] | 32,816.45 | 1.3.3.30 | CONS | CONS | ZONE-3 | ROAD-5 | MECH | SEA-W |  |  |  |  |  |  |  |  |
| CON-Z3-UT-SEA-PL-370 |  | Compaction and Sanbedding | 3d | 2016-12-17 | 2016-12-20 | CON-Z3-UT-SEA-PL-360 SS+3.2d | 159.8d | 0d | Common Labor / Helper [156 h]; Driver - Dump Truck [39 h]; Operator - Roller-Compactor (2~10 Ton) [39 h]; Driver - Water Tanker [39 h]; Operator - JCB [39 h]; Roller-Compactor (2~10 Ton) [42 h]; Plate Compactor [42 h]; Vibrators [42 h]; Water Tanker [42 h]; JCB [42 h] | 21,877.63 | 1.3.3.30 | CONS | CONS | ZONE-3 | ROAD-5 | MECH | SEA-W |  |  |  |  |  |  |  |  |
| CON-Z3-UT-SEA-PL-380 |  | Pipe Laying | 9.6d | 2016-12-19 | 2016-12-31 | CON-Z3-UT-SEA-PL-370 SS+2.4d | 159.8d | 0d | Mobile Crane ( 25-60 Ton) [134.4 h]; Flat Bed Trailer [134.4 h]; Plumber [624 h]; Common Labor / Helper [499.2 h]; RTR Pipe Crew [249.6 h]; Operator - Mobile Crane [124.8 h]; Driver - Flat Bed Trailer [124.8 h] | 65,632.9 | 1.3.3.30 | CONS | CONS | ZONE-3 | ROAD-5 | MECH | SEA-W |  |  |  |  |  |  |  |  |
| CON-Z3-UT-SEA-PL-390 |  | Installation of Thurst Block | 12d | 2016-12-24 | 2017-01-07 | CON-Z3-UT-SEA-PL-380 SS+4d | 174.4d | 101d | Steel Fixer [624 h]; Shuttering Carpenter [624 h]; Concrete Mason [624 h]; Common Labor / Helper [936 h]; Driver - Conc. Transit Mixers [156 h]; Operator - Concrete Pump [156 h]; Concrete Transit Mixers [168 h]; Concrete Pump [168 h] | 21,877.63 | 1.3.3.30 | CONS | CONS | ZONE-3 | ROAD-5 | MECH | SEA-W |  |  |  |  |  |  |  |  |
| CON-Z3-UT-SEA-PL-400 |  | Backfilling | 15d | 2017-05-04 | 2017-05-22 | CON-Z3-UT-SEA-PL-340, CON-Z3-UT-SEA-PL-380, CON-Z3-UT-SEA-PL-350 FS+60d, CON-Z3-UT-SEA-PL-390 | 73.4d | 0d | Common Labor / Helper [104 h]; Operator - Loader [150 h]; Driver - Dump Truck [150 h]; Operator - Bobcat [150 h]; Operator - Asphalt Compactor / Roller [150 h]; Operator - Roller-Compactor (2~10 Ton) [150 h]; Driver - Water Tanker [150 h]; Operator - JCB [150 h]; Loader [210 h]; Dump Truck [210 h]; Bobcat [210 h]; Roller-Compactor (2~10 Ton) [210 h]; Plate Compactor [210 h]; Vibrators [210 h]; Water Tanker [210 h]; JCB [210 h] | 32,816.45 | 1.3.3.30 | CONS | CONS | ZONE-3 | ROAD-5 | MECH | SEA-W |  |  |  |  |  |  |  |  |
| CON-Z3-UT-SEA-PL-410 |  | Testing and Precommissioning | 8d | 2017-05-22 | 2017-05-31 | CON-Z3-UT-SEA-PL-400 | 73.4d | 0d | Plumber [52 h]; Common Labor / Helper [52 h]; RTR Pipe Crew [52 h]; Driver - Water Tanker [26 h]; Water Tanker [28 h] | 43,755.27 | 1.3.3.30 | CONS | CONS | ZONE-3 | ROAD-5 | MECH | SEA-W |  |  |  |  |  |  |  |  |
|  | 2 | **Sea Water Chambers** |  | 2017-03-04 | 2017-08-03 |  |  |  |  |  |  |  |  |  |  |  |  |  |  |  |  |  |  |  |  |
|  | 2 | **Air Release Valve Chamber (AV-9) Junction of Road 3/Road A** |  | 2017-03-04 | 2017-04-05 |  |  |  |  |  |  |  |  |  |  |  |  |  |  |  |  |  |  |  |  |
| CON-Z3-UT-SW-VC-0010 |  | Excavation and Compaction | 1.6d | 2017-03-04 | 2017-03-05 | CON-Z3-UT-SEA-PL-360 FS+66d | 30.8d | 0d | Operator - Excavator [26 h] | 1,715.89 | 1.3.3.30 | CONS | CONS | ZONE-3 | ROAD-3 | MECH | SEA-W | 0 | 0 | 0.0030836221 | 6 | RPI - CONS | Z2 | PW | MECH |
| CON-Z3-UT-SW-VC-0020 |  | Lean concrete | 0.8d | 2017-03-05 | 2017-03-06 | CON-Z3-UT-SW-VC-0010, PR-Z3-UT-PW-133-0080 | 129.8d | 0d | Concrete Mason [52 h]; Driver - Conc. Transit Mixers [26 h]; Operator - Concrete Pump [26 h] | 1,029.54 | 1.3.3.30 | CONS | CONS | ZONE-3 | ROAD-3 | MECH | SEA-W | 0 | 0 | 0.0003088871 | 6 | RPI - CONS | Z2 | PW | MECH |
| CON-Z3-UT-SW-VC-0050 |  | Formwork for Base Slab | 0.8d | 2017-03-06 | 2017-03-07 | CON-Z3-UT-SW-VC-0020 | 129.8d | 0d | Shuttering Carpenter [78 h]; Common Labor / Helper [52 h] | 1,715.89 | 1.3.3.30 | CONS | CONS | ZONE-3 | ROAD-3 | MECH | SEA-W | 0 | 0 | 0.000308358 | 6 | RPI - CONS | Z2 | PW | MECH |
| CON-Z3-UT-SW-VC-0030 |  | Fabrication & installation of Rebar for Base Slab | 4d | 2017-03-07 | 2017-03-12 | PR-Z3-CW-CW-25-0080, CON-Z3-UT-SW-VC-0050 | 129.8d | 0d | Steel Fixer [78 h] | 1,715.89 | 1.3.3.30 | CONS | CONS | ZONE-3 | ROAD-3 | MECH | SEA-W | 0 | 0 | 0.0015418111 | 6 | RPI - CONS | Z2 | PW | MECH |
| CON-Z3-UT-SW-VC-0040 |  | Fabrication & installation of Rebar for Side walls | 4d | 2017-03-12 | 2017-03-16 | CON-Z3-UT-SW-VC-0030 | 129.8d | 0d | Steel Fixer [78 h] | 1,715.89 | 1.3.3.30 | CONS | CONS | ZONE-3 | ROAD-3 | MECH | SEA-W | 0 | 0 | 0.0030836221 | 6 | RPI - CONS | Z2 | PW | MECH |
| CON-Z3-UT-SW-VC-0070 |  | Formwork for side walls | 4d | 2017-03-13 | 2017-03-18 | CON-Z3-UT-SW-VC-0040 SS+0.8d | 129.8d | 0d | Shuttering Carpenter [78 h]; Common Labor / Helper [26 h]; Scaffolder [52 h] | 3,431.79 | 1.3.3.30 | CONS | CONS | ZONE-3 | ROAD-3 | MECH | SEA-W | 0 | 0 | 0.0015418111 | 6 | RPI - CONS | Z2 | PW | MECH |
| CON-Z3-UT-SW-VC-0060 |  | Concrete pouring for base slab | 0.8d | 2017-03-18 | 2017-03-18 | PR-Z3-UT-PW-133-0080, CON-Z3-UT-SW-VC-0070 | 129.8d | 0d | Concrete Mason [78 h]; Common Labor / Helper [26 h]; Finishing Work Crew [52 h]; Driver - Conc. Transit Mixers [26 h]; Operator - Concrete Pump [26 h] | 1,715.89 | 1.3.3.30 | CONS | CONS | ZONE-3 | ROAD-3 | MECH | SEA-W | 0 | 0 | 0.0015418111 | 6 | RPI - CONS | Z2 | PW | MECH |
| CON-Z3-UT-SW-VC-0080 |  | Concrete pouring for Side Wall | 0.8d | 2017-03-19 | 2017-03-19 | PR-Z3-UT-PW-133-0080, CON-Z3-UT-SW-VC-0060 | 129.8d | 0d | Common Labor / Helper [26 h]; Finishing Work Crew [52 h]; Driver - Conc. Transit Mixers [26 h]; Operator - Concrete Pump [26 h]; Concrete Mason [78 h] | 3,431.79 | 1.3.3.30 | CONS | CONS | ZONE-3 | ROAD-3 | MECH | SEA-W | 0 | 0 | 0.0040086961 | 6 | RPI - CONS | Z2 | PW | MECH |
| CON-Z3-UT-SW-VC-0090 |  | Formwork removal and concrete patching | 1.6d | 2017-03-19 | 2017-03-21 | CON-Z3-UT-SW-VC-0080 | 129.8d | 0d | Shuttering Carpenter [78 h]; Scaffolder [26 h]; Finishing Work Crew [52 h] | 686.36 | 1.3.3.30 | CONS | CONS | ZONE-3 | ROAD-3 | MECH | SEA-W | 0 | 0 | 0.0015418111 | 6 | RPI - CONS | Z2 | PW | MECH |
| CON-Z3-UT-SW-VC-0110 |  | Concrete Supports | 0.8d | 2017-03-21 | 2017-03-22 | CON-Z3-UT-SW-VC-0090 | 129.8d | 0d | Shuttering Carpenter [26 h]; Concrete Mason [26 h]; Common Labor / Helper [26 h] | 1,029.54 | 1.3.3.30 | CONS | CONS | ZONE-3 | ROAD-3 | MECH | SEA-W | 0 | 0 | 0.000616716 | 6 | RPI - CONS | Z2 | PW | MECH |
| CON-Z3-UT-SW-VC-0100 |  | Installation of Pipe Connections / Closing of Openings | 3.2d | 2017-03-22 | 2017-03-26 | CON-Z3-UT-SW-VC-0110 | 129.8d | 0d | Shuttering Carpenter [26 h]; Concrete Mason [26 h]; Plumber [160 h]; Common Labor / Helper [26 h] | 5,147.68 | 1.3.3.30 | CONS | CONS | ZONE-3 | ROAD-3 | MECH | SEA-W | 0 | 0 | 0.0055505071 | 6 | RPI - CONS | Z2 | PW | MECH |
| CON-Z3-UT-SW-VC-0140 |  | Installation of Gate valves | 3d | 2017-03-22 | 2017-03-26 | PR-Z3-UT-PW-134-0080, CON-Z3-UT-SW-VC-0100 SS | 132.4d | 0d | Common Labor / Helper [26 h]; RTR Pipe Crew [26 h] | 2,402.25 | 1.3.3.30 | CONS | CONS | ZONE-3 | ROAD-3 | MECH | SEA-W | 0 | 0 | 0.002466885 | 6 | RPI - CONS | Z2 | PW | MECH |
| CON-Z3-UT-SW-VC-0150 |  | Installation of Air Release Valves | 2.4d | 2017-03-26 | 2017-03-28 | CON-Z3-UT-SW-VC-0140, PR-Z3-UT-PW-134-0080 | 132.4d | 2.6d | Common Labor / Helper [26 h]; RTR Pipe Crew [26 h] | 3,431.79 | 1.3.3.30 | CONS | CONS | ZONE-3 | ROAD-3 | MECH | SEA-W |  |  |  |  |  |  |  |  |
| CON-Z3-UT-SW-VC-0120 |  | Damp Proof Coating | 0.8d | 2017-03-26 | 2017-03-27 | CON-Z3-UT-SW-VC-0090, CON-Z3-UT-SW-VC-0100 | 129.8d | 0d | Painter [10.4 h]; Water Proofing Crew [10.4 h] | 686.36 | 1.3.3.30 | CONS | CONS | ZONE-3 | ROAD-3 | MECH | SEA-W | 0 | 0 | 0.0015418111 | 6 | RPI - CONS | Z2 | PW | MECH |
| CON-Z3-UT-SW-VC-0130 |  | Backfilling & Compaction | 4d | 2017-03-27 | 2017-04-01 | PR-Z3-CW-CW-26-0080, CON-Z3-UT-SW-VC-0120 | 129.8d | 0d | Common Labor / Helper [52 h]; Driver - Dump Truck [26 h]; Operator - Bobcat [26 h]; Operator - Roller-Compactor (2~10 Ton) [26 h]; Driver - Water Tanker [26 h]; Operator - JCB [26 h]; Bobcat [28 h]; Plate Compactor [28 h]; Vibrators [28 h]; Water Tanker [28 h]; JCB [28 h] | 1,715.89 | 1.3.3.30 | CONS | CONS | ZONE-3 | ROAD-3 | MECH | SEA-W | 0 | 0 | 0.0037003381 | 6 | RPI - CONS | Z2 | PW | MECH |
| CON-Z3-UT-SW-VC-0160 |  | Installation of Roof Slab, Manhole Cover, Accessories & Finishes | 4d | 2017-04-01 | 2017-04-05 | CON-Z3-UT-SW-VC-0130, CON-Z3-UT-SW-VC-0150 | 129.8d | 6.6d | Common Labor / Helper [260 h]; Finishing Work Crew [120 h] | 2,745.43 | 1.3.3.30 | CONS | CONS | ZONE-3 | ROAD-3 | MECH | SEA-W |  |  |  |  |  |  |  |  |

Notes:
- CON-Z3-UT-SEA-PL-300: Expenses: (New Expense Item) 32816.4
- CON-Z3-UT-SEA-PL-310: Expenses: (New Expense Item) 21877.6
- CON-Z3-UT-SEA-PL-320: Expenses: (New Expense Item) 65632.9
- CON-Z3-UT-SEA-PL-330: Expenses: (New Expense Item) 21877.6
- CON-Z3-UT-SEA-PL-340: Expenses: (New Expense Item) 32816.4
- CON-Z3-UT-SEA-PL-350: Expenses: (New Expense Item) 43755.3
- CON-Z3-UT-SEA-PL-360: Expenses: (New Expense Item) 32816.4
- CON-Z3-UT-SEA-PL-370: Expenses: (New Expense Item) 21877.6
- CON-Z3-UT-SEA-PL-380: Expenses: (New Expense Item) 65632.9
- CON-Z3-UT-SEA-PL-390: Expenses: (New Expense Item) 21877.6
- CON-Z3-UT-SEA-PL-400: Expenses: (New Expense Item) 32816.4
- CON-Z3-UT-SEA-PL-410: Expenses: (New Expense Item) 43755.3
- CON-Z3-UT-SW-VC-0010: Expenses: (New Expense Item) 1715.89
- CON-Z3-UT-SW-VC-0020: Expenses: (New Expense Item) 1029.54
- CON-Z3-UT-SW-VC-0050: Expenses: (New Expense Item) 1715.89
- CON-Z3-UT-SW-VC-0030: Expenses: (New Expense Item) 1715.89
- CON-Z3-UT-SW-VC-0040: Expenses: (New Expense Item) 1715.89
- CON-Z3-UT-SW-VC-0070: Expenses: (New Expense Item) 3431.79
- CON-Z3-UT-SW-VC-0060: Expenses: (New Expense Item) 1715.89
- CON-Z3-UT-SW-VC-0080: Expenses: (New Expense Item) 3431.79
- CON-Z3-UT-SW-VC-0090: Expenses: (New Expense Item) 686.36
- CON-Z3-UT-SW-VC-0110: Expenses: (New Expense Item) 1029.54
- CON-Z3-UT-SW-VC-0100: Expenses: (New Expense Item) 5147.68
- CON-Z3-UT-SW-VC-0140: Expenses: (New Expense Item) 2402.25
- CON-Z3-UT-SW-VC-0150: Expenses: (New Expense Item) 3431.79
- CON-Z3-UT-SW-VC-0120: Expenses: (New Expense Item) 686.36
- CON-Z3-UT-SW-VC-0130: Expenses: (New Expense Item) 1715.89
- CON-Z3-UT-SW-VC-0160: Expenses: (New Expense Item) 2745.43

| ID | WBS | Activity | Duration | Start | Finish | Predecessors | Total float | Free float | Resources | Cost | Activity Wt% | Weight % | Cost Wt | RPI - PHASE | RPI - CONSTRUCTION | RPI - ZONES | RPI - UTILITY NETWORKS | RPI - TYPE OF WORK | RPI_P2 - BOQ ITEMS | RPI_P2 - CONSTRUCTION | RPI_P2 - PHASE | RPI_P2 - ZONES | RPI_P2 - AREAS | RPI_P2 - DISCIPLINE / WORK TYPE | RPI_P2 - UTILITY NETWORK |
| --- | --- | --- | --- | --- | --- | --- | --- | --- | --- | --- | --- | --- | --- | --- | --- | --- | --- | --- | --- | --- | --- | --- | --- | --- | --- |
|  | 16 | **Isolation Valve Chamber (ISV-2) at Junction of Road 3/Road A** |  | 2017-03-11 | 2017-04-12 |  |  |  |  |  |  |  |  |  |  |  |  |  |  |  |  |  |  |  |  |
| CON-Z3-UT-SW-VC-0440 |  | Excavation and Compaction | 1.6d | 2017-03-11 | 2017-03-13 | CON-Z3-UT-SW-VC-0010 FS+5d | 30.8d | 0d | Operator - Excavator [26 h] | 1,715.89 | 0 | 0 | 0.0030836221 | 6 | RPI - CONS | Z2 | PW | MECH | 1.3.3.30 | CONS | CONS | ZONE-3 | ROAD-3 | MECH | SEA-W |
| CON-Z3-UT-SW-VC-0450 |  | Lean concrete | 0.8d | 2017-03-13 | 2017-03-14 | CON-Z3-UT-SW-VC-0440 | 123.2d | 0d | Concrete Mason [10.4 h]; Driver - Conc. Transit Mixers [10.4 h]; Operator - Concrete Pump [10.4 h] | 1,029.54 | 0 | 0 | 0.0003088871 | 6 | RPI - CONS | Z2 | PW | MECH | 1.3.3.30 | CONS | CONS | ZONE-3 | ROAD-3 | MECH | SEA-W |
| CON-Z3-UT-SW-VC-0480 |  | Formwork for Base Slab | 0.8d | 2017-03-14 | 2017-03-14 | CON-Z3-UT-SW-VC-0450 | 123.2d | 0d | Shuttering Carpenter [20.8 h]; Common Labor / Helper [20.8 h] | 1,715.89 | 0 | 0 | 0.000308358 | 6 | RPI - CONS | Z2 | PW | MECH | 1.3.3.30 | CONS | CONS | ZONE-3 | ROAD-3 | MECH | SEA-W |
| CON-Z3-UT-SW-VC-0460 |  | Fabrication & installation of Rebar for Base Slab | 4d | 2017-03-15 | 2017-03-19 | CON-Z3-UT-SW-VC-0480 | 123.2d | 0d | Steel Fixer [78 h] | 1,715.89 | 0 | 0 | 0.0015418111 | 6 | RPI - CONS | Z2 | PW | MECH | 1.3.3.30 | CONS | CONS | ZONE-3 | ROAD-3 | MECH | SEA-W |
| CON-Z3-UT-SW-VC-0470 |  | Fabrication & installation of Rebar for Side walls | 4d | 2017-03-20 | 2017-03-23 | CON-Z3-UT-SW-VC-0460 | 123.2d | 0d | Steel Fixer [78 h] | 1,715.89 | 0 | 0 | 0.0030836221 | 6 | RPI - CONS | Z2 | PW | MECH | 1.3.3.30 | CONS | CONS | ZONE-3 | ROAD-3 | MECH | SEA-W |
| CON-Z3-UT-SW-VC-0500 |  | Formwork for side walls | 4d | 2017-03-20 | 2017-03-25 | CON-Z3-UT-SW-VC-0470 SS+0.8d | 123.2d | 0d | Shuttering Carpenter [78 h]; Common Labor / Helper [26 h]; Scaffolder [52 h] | 3,431.79 | 0 | 0 | 0.0015418111 | 6 | RPI - CONS | Z2 | PW | MECH | 1.3.3.30 | CONS | CONS | ZONE-3 | ROAD-3 | MECH | SEA-W |
| CON-Z3-UT-SW-VC-0490 |  | Concrete pouring for base slab | 0.8d | 2017-03-25 | 2017-03-26 | CON-Z3-UT-SW-VC-0500 | 123.2d | 0d | Common Labor / Helper [26 h]; Finishing Work Crew [52 h]; Driver - Conc. Transit Mixers [26 h]; Operator - Concrete Pump [26 h]; Concrete Mason [78 h] | 1,715.89 | 0 | 0 | 0.0015418111 | 6 | RPI - CONS | Z2 | PW | MECH | 1.3.3.30 | CONS | CONS | ZONE-3 | ROAD-3 | MECH | SEA-W |
| CON-Z3-UT-SW-VC-0510 |  | Concrete pouring for Side Wall | 0.8d | 2017-03-26 | 2017-03-27 | CON-Z3-UT-SW-VC-0490 | 123.2d | 0d | Concrete Mason [20.8 h]; Common Labor / Helper [26 h]; Finishing Work Crew [20.8 h]; Driver - Conc. Transit Mixers [26 h]; Operator - Concrete Pump [26 h] | 3,431.79 | 0 | 0 | 0.0040086961 | 6 | RPI - CONS | Z2 | PW | MECH | 1.3.3.30 | CONS | CONS | ZONE-3 | ROAD-3 | MECH | SEA-W |
| CON-Z3-UT-SW-VC-0520 |  | Formwork removal and concrete patching | 1.6d | 2017-03-27 | 2017-03-28 | CON-Z3-UT-SW-VC-0510 | 123.2d | 0d | Shuttering Carpenter [78 h]; Scaffolder [26 h]; Finishing Work Crew [52 h] | 686.36 | 0 | 0 | 0.0015418111 | 6 | RPI - CONS | Z2 | PW | MECH | 1.3.3.30 | CONS | CONS | ZONE-3 | ROAD-3 | MECH | SEA-W |
| CON-Z3-UT-SW-VC-0540 |  | Concrete Supports | 0.8d | 2017-03-29 | 2017-03-29 | CON-Z3-UT-SW-VC-0520 | 123.2d | 0d | Shuttering Carpenter [26 h]; Concrete Mason [26 h]; Common Labor / Helper [26 h] | 1,029.54 | 0 | 0 | 0.000616716 | 6 | RPI - CONS | Z2 | PW | MECH | 1.3.3.30 | CONS | CONS | ZONE-3 | ROAD-3 | MECH | SEA-W |
| CON-Z3-UT-SW-VC-0530 |  | Installation of Pipe Connections / Closing of Openings | 3.2d | 2017-03-29 | 2017-04-02 | CON-Z3-UT-SW-VC-0540 | 123.2d | 0d | Shuttering Carpenter [26 h]; Concrete Mason [26 h]; Plumber [160 h]; Common Labor / Helper [26 h] | 5,147.68 | 0 | 0 | 0.0055505071 | 6 | RPI - CONS | Z2 | PW | MECH | 1.3.3.30 | CONS | CONS | ZONE-3 | ROAD-3 | MECH | SEA-W |
| CON-Z3-UT-SW-VC-8180 |  | Installation of Dismantling joints | 2.4d | 2017-03-29 | 2017-04-02 | PR-Z3-UT-PW-135-0080, CON-Z3-UT-SW-VC-0530 SS | 124.8d | 0d | Common Labor / Helper [26 h]; RTR Pipe Crew [26 h] | 2,402.25 |  |  |  |  |  |  |  |  | 1.3.3.30 | CONS | CONS | ZONE-3 | ROAD-3 | MECH | SEA-W |
| CON-Z3-UT-SW-VC-8190 |  | Installation of Valves | 4d | 2017-04-02 | 2017-04-06 | PR-Z3-UT-PW-134-0080, CON-Z3-UT-SW-VC-8180 | 124.8d | 1.6d | Common Labor / Helper [312 h]; RTR Pipe Crew [52 h] | 3,431.79 |  |  |  |  |  |  |  |  | 1.3.3.30 | CONS | CONS | ZONE-3 | ROAD-3 | MECH | SEA-W |
| CON-Z3-UT-SW-VC-0550 |  | Damp Proof Coating | 0.8d | 2017-04-03 | 2017-04-03 | CON-Z3-UT-SW-VC-0520, CON-Z3-UT-SW-VC-0530 | 123.2d | 0d | Painter [80 h]; Water Proofing Crew [52 h] | 686.36 | 0 | 0 | 0.0015418111 | 6 | RPI - CONS | Z2 | PW | MECH | 1.3.3.30 | CONS | CONS | ZONE-3 | ROAD-3 | MECH | SEA-W |
| CON-Z3-UT-SW-VC-0560 |  | Backfilling & Compaction | 4d | 2017-04-03 | 2017-04-08 | CON-Z3-UT-SW-VC-0550 | 123.2d | 0d | Common Labor / Helper [312 h]; Driver - Dump Truck [52 h]; Operator - Bobcat [52 h]; Operator - Roller-Compactor (2~10 Ton) [52 h]; Driver - Water Tanker [52 h]; Operator - JCB [52 h]; Bobcat [56 h]; Plate Compactor [56 h]; Vibrators [56 h]; Water Tanker [56 h]; JCB [56 h] | 1,715.89 | 0 | 0 | 0.0037003381 | 6 | RPI - CONS | Z2 | PW | MECH | 1.3.3.30 | CONS | CONS | ZONE-3 | ROAD-3 | MECH | SEA-W |
| CON-Z3-UT-SW-VC-8200 |  | Installation of Roof Slab, Manhole Cover, Accessories & Finishes | 4d | 2017-04-08 | 2017-04-12 | CON-Z3-UT-SW-VC-0160 SS, CON-Z3-UT-SW-VC-0560, CON-Z3-UT-SW-VC-8190 | 123.2d | 6.6d | Common Labor / Helper [312 h]; Finishing Work Crew [52 h] | 2,745.43 |  |  |  |  |  |  |  |  | 1.3.3.30 | CONS | CONS | ZONE-3 | ROAD-3 | MECH | SEA-W |
|  | 4 | **Chamber - VB-NCL-17 at Road 3** |  | 2017-03-19 | 2017-04-20 |  |  |  |  |  |  |  |  |  |  |  |  |  |  |  |  |  |  |  |  |
| CON-Z3-UT-SW-VC-0580 |  | Excavation and Compaction | 1.6d | 2017-03-19 | 2017-03-20 | CON-Z3-UT-SW-VC-0440 FS+5d | 30.8d | 0d | Operator - Excavator [26 h] | 1,715.89 | 0 | 0 | 0.0030836221 | 6 | RPI - CONS | Z2 | PW | MECH | 1.3.3.30 | CONS | CONS | ZONE-3 | ROAD-3 | MECH | SEA-W |
| CON-Z3-UT-SW-VC-0590 |  | Lean concrete | 0.8d | 2017-03-21 | 2017-03-21 | CON-Z3-UT-SW-VC-0580 | 116.6d | 0d | Concrete Mason [10.4 h]; Driver - Conc. Transit Mixers [10.4 h]; Operator - Concrete Pump [10.4 h] | 1,029.54 | 0 | 0 | 0.0003088871 | 6 | RPI - CONS | Z2 | PW | MECH | 1.3.3.30 | CONS | CONS | ZONE-3 | ROAD-3 | MECH | SEA-W |
| CON-Z3-UT-SW-VC-0620 |  | Formwork for Base Slab | 0.8d | 2017-03-21 | 2017-03-22 | CON-Z3-UT-SW-VC-0590 | 116.6d | 0d | Shuttering Carpenter [31.2 h]; Common Labor / Helper [20.8 h] | 1,715.89 | 0 | 0 | 0.000308358 | 6 | RPI - CONS | Z2 | PW | MECH | 1.3.3.30 | CONS | CONS | ZONE-3 | ROAD-3 | MECH | SEA-W |
| CON-Z3-UT-SW-VC-0600 |  | Fabrication & installation of Rebar for Base Slab | 4d | 2017-03-22 | 2017-03-27 | CON-Z3-UT-SW-VC-0620 | 116.6d | 0d | Steel Fixer [78 h] | 1,715.89 | 0 | 0 | 0.0015418111 | 6 | RPI - CONS | Z2 | PW | MECH | 1.3.3.30 | CONS | CONS | ZONE-3 | ROAD-3 | MECH | SEA-W |
| CON-Z3-UT-SW-VC-0610 |  | Fabrication & installation of Rebar for Side walls | 4d | 2017-03-27 | 2017-04-01 | CON-Z3-UT-SW-VC-0600 | 116.6d | 0d | Steel Fixer [78 h] | 1,715.89 | 0 | 0 | 0.0030836221 | 6 | RPI - CONS | Z2 | PW | MECH | 1.3.3.30 | CONS | CONS | ZONE-3 | ROAD-3 | MECH | SEA-W |
| CON-Z3-UT-SW-VC-0640 |  | Formwork for side walls | 4d | 2017-03-28 | 2017-04-02 | CON-Z3-UT-SW-VC-0610 SS+0.8d | 116.6d | 0d | Shuttering Carpenter [78 h]; Common Labor / Helper [26 h]; Scaffolder [52 h] | 3,431.79 | 0 | 0 | 0.0015418111 | 6 | RPI - CONS | Z2 | PW | MECH | 1.3.3.30 | CONS | CONS | ZONE-3 | ROAD-3 | MECH | SEA-W |
| CON-Z3-UT-SW-VC-0630 |  | Concrete pouring for base slab | 0.8d | 2017-04-02 | 2017-04-03 | CON-Z3-UT-SW-VC-0640 | 116.6d | 0d | Concrete Mason [78 h]; Common Labor / Helper [62.4 h]; Finishing Work Crew [52 h]; Driver - Conc. Transit Mixers [26 h]; Operator - Concrete Pump [26 h] | 1,715.89 | 0 | 0 | 0.0015418111 | 6 | RPI - CONS | Z2 | PW | MECH | 1.3.3.30 | CONS | CONS | ZONE-3 | ROAD-3 | MECH | SEA-W |
| CON-Z3-UT-SW-VC-0650 |  | Concrete pouring for Side Wall | 0.8d | 2017-04-03 | 2017-04-03 | CON-Z3-UT-SW-VC-0630 | 116.6d | 0d | Concrete Mason [78 h]; Common Labor / Helper [62.4 h]; Finishing Work Crew [52 h]; Driver - Conc. Transit Mixers [26 h]; Operator - Concrete Pump [26 h] | 3,431.79 | 0 | 0 | 0.0040086961 | 6 | RPI - CONS | Z2 | PW | MECH | 1.3.3.30 | CONS | CONS | ZONE-3 | ROAD-3 | MECH | SEA-W |
| CON-Z3-UT-SW-VC-0660 |  | Formwork removal and concrete patching | 1.6d | 2017-04-04 | 2017-04-05 | CON-Z3-UT-SW-VC-0650 | 116.6d | 0d | Shuttering Carpenter [78 h]; Scaffolder [26 h]; Finishing Work Crew [52 h] | 686.36 | 0 | 0 | 0.0015418111 | 6 | RPI - CONS | Z2 | PW | MECH | 1.3.3.30 | CONS | CONS | ZONE-3 | ROAD-3 | MECH | SEA-W |
| CON-Z3-UT-SW-VC-0680 |  | Concrete Supports | 0.8d | 2017-04-05 | 2017-04-06 | CON-Z3-UT-SW-VC-0660 | 116.6d | 0d | Shuttering Carpenter [62.4 h]; Concrete Mason [62.4 h]; Common Labor / Helper [62.4 h] | 1,029.54 | 0 | 0 | 0.000616716 | 6 | RPI - CONS | Z2 | PW | MECH | 1.3.3.30 | CONS | CONS | ZONE-3 | ROAD-3 | MECH | SEA-W |
| CON-Z3-UT-SW-VC-0670 |  | Installation of Pipe Connections / Closing of Openings | 3.2d | 2017-04-06 | 2017-04-10 | CON-Z3-UT-SW-VC-0680 | 116.6d | 0d | Shuttering Carpenter [26 h]; Concrete Mason [26 h]; Plumber [26 h]; Common Labor / Helper [26 h] | 5,147.68 | 0 | 0 | 0.0055505071 | 6 | RPI - CONS | Z2 | PW | MECH | 1.3.3.30 | CONS | CONS | ZONE-3 | ROAD-3 | MECH | SEA-W |
| CON-Z3-UT-SW-VC-8210 |  | Installation of Dismantling joints | 2.4d | 2017-04-06 | 2017-04-09 | CON-Z3-UT-SW-VC-0670 SS, PR-Z3-UT-PW-135-0080 | 118.2d | 0d | Common Labor / Helper [187.2 h]; RTR Pipe Crew [31.2 h] | 2,402.25 |  |  |  |  |  |  |  |  | 1.3.3.30 | CONS | CONS | ZONE-3 | ROAD-3 | MECH | SEA-W |
| CON-Z3-UT-SW-VC-8220 |  | Installation of Valves | 4d | 2017-04-09 | 2017-04-13 | CON-Z3-UT-SW-VC-8210, PR-Z3-UT-PW-134-0080 | 118.2d | 1.6d | Common Labor / Helper [312 h]; RTR Pipe Crew [52 h] | 3,431.79 |  |  |  |  |  |  |  |  | 1.3.3.30 | CONS | CONS | ZONE-3 | ROAD-3 | MECH | SEA-W |
| CON-Z3-UT-SW-VC-0690 |  | Damp Proof Coating | 0.8d | 2017-04-10 | 2017-04-11 | CON-Z3-UT-SW-VC-0660, CON-Z3-UT-SW-VC-0670 | 116.6d | 0d | Painter [52 h]; Water Proofing Crew [52 h] | 686.36 | 0 | 0 | 0.0015418111 | 6 | RPI - CONS | Z2 | PW | MECH | 1.3.3.30 | CONS | CONS | ZONE-3 | ROAD-3 | MECH | SEA-W |
| CON-Z3-UT-SW-VC-0700 |  | Backfilling & Compaction | 4d | 2017-04-11 | 2017-04-16 | CON-Z3-UT-SW-VC-0690 | 116.6d | 0d | Common Labor / Helper [416 h]; Driver - Dump Truck [52 h]; Operator - Bobcat [52 h]; Operator - Roller-Compactor (2~10 Ton) [52 h]; Driver - Water Tanker [52 h]; Operator - JCB [52 h]; Bobcat [56 h]; Plate Compactor [56 h]; Vibrators [56 h]; Water Tanker [56 h]; JCB [56 h] | 1,715.89 | 0 | 0 | 0.0037003381 | 6 | RPI - CONS | Z2 | PW | MECH | 1.3.3.30 | CONS | CONS | ZONE-3 | ROAD-3 | MECH | SEA-W |
| CON-Z3-UT-SW-VC-8230 |  | Installation of Roof Slab, Manhole Cover, Accessories & Finishes | 4d | 2017-04-16 | 2017-04-20 | CON-Z3-UT-SW-VC-8220, CON-Z3-UT-SW-VC-0700, CON-Z3-UT-SW-VC-8200 SS | 116.6d | 6.6d | Common Labor / Helper [416 h]; Finishing Work Crew [52 h] | 2,745.43 |  |  |  |  |  |  |  |  | 1.3.3.30 | CONS | CONS | ZONE-3 | ROAD-3 | MECH | SEA-W |

Notes:
- CON-Z3-UT-SW-VC-0440: Expenses: (New Expense Item) 1715.89
- CON-Z3-UT-SW-VC-0450: Expenses: (New Expense Item) 1029.54
- CON-Z3-UT-SW-VC-0480: Expenses: (New Expense Item) 1715.89
- CON-Z3-UT-SW-VC-0460: Expenses: (New Expense Item) 1715.89
- CON-Z3-UT-SW-VC-0470: Expenses: (New Expense Item) 1715.89
- CON-Z3-UT-SW-VC-0500: Expenses: (New Expense Item) 3431.79
- CON-Z3-UT-SW-VC-0490: Expenses: (New Expense Item) 1715.89
- CON-Z3-UT-SW-VC-0510: Expenses: (New Expense Item) 3431.79
- CON-Z3-UT-SW-VC-0520: Expenses: (New Expense Item) 686.36
- CON-Z3-UT-SW-VC-0540: Expenses: (New Expense Item) 1029.54
- CON-Z3-UT-SW-VC-0530: Expenses: (New Expense Item) 5147.68
- CON-Z3-UT-SW-VC-8180: Expenses: (New Expense Item) 2402.25
- CON-Z3-UT-SW-VC-8190: Expenses: (New Expense Item) 3431.79
- CON-Z3-UT-SW-VC-0550: Expenses: (New Expense Item) 686.36
- CON-Z3-UT-SW-VC-0560: Expenses: (New Expense Item) 1715.89
- CON-Z3-UT-SW-VC-8200: Expenses: (New Expense Item) 2745.43
- CON-Z3-UT-SW-VC-0580: Expenses: (New Expense Item) 1715.89
- CON-Z3-UT-SW-VC-0590: Expenses: (New Expense Item) 1029.54
- CON-Z3-UT-SW-VC-0620: Expenses: (New Expense Item) 1715.89
- CON-Z3-UT-SW-VC-0600: Expenses: (New Expense Item) 1715.89
- CON-Z3-UT-SW-VC-0610: Expenses: (New Expense Item) 1715.89
- CON-Z3-UT-SW-VC-0640: Expenses: (New Expense Item) 3431.79
- CON-Z3-UT-SW-VC-0630: Expenses: (New Expense Item) 1715.89
- CON-Z3-UT-SW-VC-0650: Expenses: (New Expense Item) 3431.79
- CON-Z3-UT-SW-VC-0660: Expenses: (New Expense Item) 686.36
- CON-Z3-UT-SW-VC-0680: Expenses: (New Expense Item) 1029.54
- CON-Z3-UT-SW-VC-0670: Expenses: (New Expense Item) 5147.68
- CON-Z3-UT-SW-VC-8210: Expenses: (New Expense Item) 2402.25
- CON-Z3-UT-SW-VC-8220: Expenses: (New Expense Item) 3431.79
- CON-Z3-UT-SW-VC-0690: Expenses: (New Expense Item) 686.36
- CON-Z3-UT-SW-VC-0700: Expenses: (New Expense Item) 1715.89
- CON-Z3-UT-SW-VC-8230: Expenses: (New Expense Item) 2745.43

| ID | WBS | Activity | Duration | Start | Finish | Predecessors | Total float | Free float | Resources | Cost | Activity Wt% | Weight % | Cost Wt | RPI - PHASE | RPI - CONSTRUCTION | RPI - ZONES | RPI - UTILITY NETWORKS | RPI - TYPE OF WORK | RPI_P2 - BOQ ITEMS | RPI_P2 - CONSTRUCTION | RPI_P2 - PHASE | RPI_P2 - ZONES | RPI_P2 - AREAS | RPI_P2 - DISCIPLINE / WORK TYPE | RPI_P2 - UTILITY NETWORK |
| --- | --- | --- | --- | --- | --- | --- | --- | --- | --- | --- | --- | --- | --- | --- | --- | --- | --- | --- | --- | --- | --- | --- | --- | --- | --- |
|  | 5 | **Chamber - VB-NCL-13 at Road 3** |  | 2017-03-27 | 2017-04-27 |  |  |  |  |  |  |  |  |  |  |  |  |  |  |  |  |  |  |  |  |
| CON-Z3-UT-SW-VC-0720 |  | Excavation and Compaction | 1.6d | 2017-03-27 | 2017-03-28 | CON-Z3-UT-SW-VC-0580 FS+5d | 30.8d | 0d | Operator - Excavator [26 h] | 1,715.89 | 0 | 0 | 0.0030836221 | 6 | RPI - CONS | Z2 | PW | MECH | 1.3.3.30 | CONS | CONS | ZONE-3 | ROAD-3 | MECH | SEA-W |
| CON-Z3-UT-SW-VC-0730 |  | Lean concrete | 0.8d | 2017-03-28 | 2017-03-29 | CON-Z3-UT-SW-VC-0720 | 110d | 0d | Concrete Mason [52 h]; Driver - Conc. Transit Mixers [26 h]; Operator - Concrete Pump [26 h] | 1,029.54 | 0 | 0 | 0.0003088871 | 6 | RPI - CONS | Z2 | PW | MECH | 1.3.3.30 | CONS | CONS | ZONE-3 | ROAD-3 | MECH | SEA-W |
| CON-Z3-UT-SW-VC-0760 |  | Formwork for Base Slab | 0.8d | 2017-03-29 | 2017-03-30 | CON-Z3-UT-SW-VC-0730 | 110d | 0d | Shuttering Carpenter [78 h]; Common Labor / Helper [52 h] | 1,715.89 | 0 | 0 | 0.000308358 | 6 | RPI - CONS | Z2 | PW | MECH | 1.3.3.30 | CONS | CONS | ZONE-3 | ROAD-3 | MECH | SEA-W |
| CON-Z3-UT-SW-VC-0740 |  | Fabrication & installation of Rebar for Base Slab | 4d | 2017-03-30 | 2017-04-04 | CON-Z3-UT-SW-VC-0760 | 110d | 0d | Steel Fixer [400 h] | 1,715.89 | 0 | 0 | 0.0015418111 | 6 | RPI - CONS | Z2 | PW | MECH | 1.3.3.30 | CONS | CONS | ZONE-3 | ROAD-3 | MECH | SEA-W |
| CON-Z3-UT-SW-VC-0750 |  | Fabrication & installation of Rebar for Side walls | 4d | 2017-04-04 | 2017-04-09 | CON-Z3-UT-SW-VC-0740 | 110d | 0d | Steel Fixer [400 h] | 1,715.89 | 0 | 0 | 0.0030836221 | 6 | RPI - CONS | Z2 | PW | MECH | 1.3.3.30 | CONS | CONS | ZONE-3 | ROAD-3 | MECH | SEA-W |
| CON-Z3-UT-SW-VC-0780 |  | Formwork for side walls | 4d | 2017-04-05 | 2017-04-09 | CON-Z3-UT-SW-VC-0750 SS+0.8d | 110d | 0d | Shuttering Carpenter [78 h]; Common Labor / Helper [26 h]; Scaffolder [200 h] | 3,431.79 | 0 | 0 | 0.0015418111 | 6 | RPI - CONS | Z2 | PW | MECH | 1.3.3.30 | CONS | CONS | ZONE-3 | ROAD-3 | MECH | SEA-W |
| CON-Z3-UT-SW-VC-0770 |  | Concrete pouring for base slab | 0.8d | 2017-04-10 | 2017-04-10 | CON-Z3-UT-SW-VC-0780 | 110d | 0d | Concrete Mason [78 h]; Common Labor / Helper [83.2 h]; Finishing Work Crew [52 h]; Driver - Conc. Transit Mixers [26 h]; Operator - Concrete Pump [26 h] | 1,715.89 | 0 | 0 | 0.0015418111 | 6 | RPI - CONS | Z2 | PW | MECH | 1.3.3.30 | CONS | CONS | ZONE-3 | ROAD-3 | MECH | SEA-W |
| CON-Z3-UT-SW-VC-0790 |  | Concrete pouring for Side Wall | 0.8d | 2017-04-10 | 2017-04-11 | CON-Z3-UT-SW-VC-0770 | 110d | 0d | Concrete Mason [78 h]; Common Labor / Helper [26 h]; Finishing Work Crew [52 h]; Driver - Conc. Transit Mixers [26 h]; Operator - Concrete Pump [26 h] | 3,431.79 | 0 | 0 | 0.0040086961 | 6 | RPI - CONS | Z2 | PW | MECH | 1.3.3.30 | CONS | CONS | ZONE-3 | ROAD-3 | MECH | SEA-W |
| CON-Z3-UT-SW-VC-0800 |  | Formwork removal and concrete patching | 1.6d | 2017-04-11 | 2017-04-13 | CON-Z3-UT-SW-VC-0790 | 110d | 0d | Shuttering Carpenter [78 h]; Scaffolder [26 h]; Finishing Work Crew [52 h] | 686.36 | 0 | 0 | 0.0015418111 | 6 | RPI - CONS | Z2 | PW | MECH | 1.3.3.30 | CONS | CONS | ZONE-3 | ROAD-3 | MECH | SEA-W |
| CON-Z3-UT-SW-VC-0820 |  | Concrete Supports | 0.8d | 2017-04-13 | 2017-04-13 | CON-Z3-UT-SW-VC-0800 | 110d | 0d | Shuttering Carpenter [26 h]; Concrete Mason [26 h]; Common Labor / Helper [26 h] | 1,029.54 | 0 | 0 | 0.000616716 | 6 | RPI - CONS | Z2 | PW | MECH | 1.3.3.30 | CONS | CONS | ZONE-3 | ROAD-3 | MECH | SEA-W |
| CON-Z3-UT-SW-VC-0810 |  | Installation of Pipe Connections / Closing of Openings | 3.2d | 2017-04-15 | 2017-04-18 | CON-Z3-UT-SW-VC-0820 | 110d | 0d | Shuttering Carpenter [26 h]; Concrete Mason [26 h]; Plumber [26 h]; Common Labor / Helper [26 h] | 5,147.68 | 0 | 0 | 0.0055505071 | 6 | RPI - CONS | Z2 | PW | MECH | 1.3.3.30 | CONS | CONS | ZONE-3 | ROAD-3 | MECH | SEA-W |
| CON-Z3-UT-SW-VC-8240 |  | Installation of Dismantling joints | 2.4d | 2017-04-15 | 2017-04-17 | CON-Z3-UT-SW-VC-0810 SS | 111.6d | 0d | Common Labor / Helper [187.2 h]; RTR Pipe Crew [31.2 h] | 2,402.25 |  |  |  |  |  |  |  |  | 1.3.3.30 | CONS | CONS | ZONE-3 | ROAD-3 | MECH | SEA-W |
| CON-Z3-UT-SW-VC-8250 |  | Installation of Valves | 4d | 2017-04-17 | 2017-04-22 | CON-Z3-UT-SW-VC-8240 | 111.6d | 1.6d | Common Labor / Helper [312 h]; RTR Pipe Crew [52 h] | 3,431.79 |  |  |  |  |  |  |  |  | 1.3.3.30 | CONS | CONS | ZONE-3 | ROAD-3 | MECH | SEA-W |
| CON-Z3-UT-SW-VC-0830 |  | Damp Proof Coating | 0.8d | 2017-04-18 | 2017-04-18 | CON-Z3-UT-SW-VC-0800, CON-Z3-UT-SW-VC-0810 | 110d | 0d | Painter [52 h]; Water Proofing Crew [52 h] | 686.36 | 0 | 0 | 0.0015418111 | 6 | RPI - CONS | Z2 | PW | MECH | 1.3.3.30 | CONS | CONS | ZONE-3 | ROAD-3 | MECH | SEA-W |
| CON-Z3-UT-SW-VC-0840 |  | Backfilling & Compaction | 4d | 2017-04-19 | 2017-04-23 | CON-Z3-UT-SW-VC-0830 | 110d | 0d | Common Labor / Helper [52 h]; Driver - Dump Truck [26 h]; Operator - Bobcat [26 h]; Operator - Roller-Compactor (2~10 Ton) [26 h]; Driver - Water Tanker [26 h]; Operator - JCB [26 h]; Bobcat [28 h]; Plate Compactor [28 h]; Vibrators [28 h]; Water Tanker [28 h]; JCB [28 h] | 1,715.89 | 0 | 0 | 0.0037003381 | 6 | RPI - CONS | Z2 | PW | MECH | 1.3.3.30 | CONS | CONS | ZONE-3 | ROAD-3 | MECH | SEA-W |
| CON-Z3-UT-SW-VC-8260 |  | Installation of Roof Slab, Manhole Cover, Accessories & Finishes | 4d | 2017-04-24 | 2017-04-27 | CON-Z3-UT-SW-VC-8250, CON-Z3-UT-SW-VC-0840, CON-Z3-UT-SW-VC-8230 SS | 110d | 11.4d | Common Labor / Helper [416 h]; Finishing Work Crew [52 h] | 2,745.43 |  |  |  |  |  |  |  |  | 1.3.3.30 | CONS | CONS | ZONE-3 | ROAD-3 | MECH | SEA-W |
|  | 6 | **Wash Down Valve Chamber (WD-11) at Road 3 R/A** |  | 2017-04-03 | 2017-05-13 |  |  |  |  |  |  |  |  |  |  |  |  |  |  |  |  |  |  |  |  |
| CON-Z3-UT-SW-VC-0860 |  | Excavation and Compaction | 1.6d | 2017-04-03 | 2017-04-05 | CON-Z3-UT-SW-VC-0720 FS+5d | 30.8d | 0d | Operator - Excavator [26 h] | 1,715.89 | 0 | 0 | 0.0030836221 | 6 | RPI - CONS | Z2 | PW | MECH | 1.3.3.30 | CONS | CONS | ZONE-3 | ROAD-3 | MECH | SEA-W |
| CON-Z3-UT-SW-VC-0870 |  | Lean concrete | 0.8d | 2017-04-05 | 2017-04-05 | CON-Z3-UT-SW-VC-0860 | 98.6d | 0d | Concrete Mason [52 h]; Driver - Conc. Transit Mixers [26 h]; Operator - Concrete Pump [26 h] | 1,029.54 | 0 | 0 | 0.0003088871 | 6 | RPI - CONS | Z2 | PW | MECH | 1.3.3.30 | CONS | CONS | ZONE-3 | ROAD-3 | MECH | SEA-W |
| CON-Z3-UT-SW-VC-0900 |  | Formwork for Base Slab | 0.8d | 2017-04-06 | 2017-04-06 | CON-Z3-UT-SW-VC-0870 | 98.6d | 0d | Shuttering Carpenter [78 h]; Common Labor / Helper [52 h] | 1,715.89 | 0 | 0 | 0.000308358 | 6 | RPI - CONS | Z2 | PW | MECH | 1.3.3.30 | CONS | CONS | ZONE-3 | ROAD-3 | MECH | SEA-W |
| CON-Z3-UT-SW-VC-0880 |  | Fabrication & installation of Rebar for Base Slab | 4d | 2017-04-06 | 2017-04-11 | CON-Z3-UT-SW-VC-0900 | 98.6d | 0d | Steel Fixer [480 h] | 1,715.89 | 0 | 0 | 0.0015418111 | 6 | RPI - CONS | Z2 | PW | MECH | 1.3.3.30 | CONS | CONS | ZONE-3 | ROAD-3 | MECH | SEA-W |
| CON-Z3-UT-SW-VC-0890 |  | Fabrication & installation of Rebar for Side walls | 4d | 2017-04-11 | 2017-04-16 | CON-Z3-UT-SW-VC-0880 | 98.6d | 0d | Steel Fixer [480 h] | 1,715.89 | 0 | 0 | 0.0030836221 | 6 | RPI - CONS | Z2 | PW | MECH | 1.3.3.30 | CONS | CONS | ZONE-3 | ROAD-3 | MECH | SEA-W |
| CON-Z3-UT-SW-VC-0920 |  | Formwork for side walls | 4d | 2017-04-12 | 2017-04-17 | CON-Z3-UT-SW-VC-0890 SS+0.8d | 98.6d | 0d | Shuttering Carpenter [260 h]; Common Labor / Helper [312 h]; Scaffolder [208 h] | 3,431.79 | 0 | 0 | 0.0015418111 | 6 | RPI - CONS | Z2 | PW | MECH | 1.3.3.30 | CONS | CONS | ZONE-3 | ROAD-3 | MECH | SEA-W |
| CON-Z3-UT-SW-VC-0910 |  | Concrete pouring for base slab | 0.8d | 2017-04-17 | 2017-04-18 | CON-Z3-UT-SW-VC-0920 | 98.6d | 0d | Concrete Mason [78 h]; Common Labor / Helper [26 h]; Finishing Work Crew [52 h]; Driver - Conc. Transit Mixers [26 h]; Operator - Concrete Pump [26 h] | 1,715.89 | 0 | 0 | 0.0015418111 | 6 | RPI - CONS | Z2 | PW | MECH | 1.3.3.30 | CONS | CONS | ZONE-3 | ROAD-3 | MECH | SEA-W |
| CON-Z3-UT-SW-VC-0930 |  | Concrete pouring for Side Wall | 0.8d | 2017-04-18 | 2017-04-19 | CON-Z3-UT-SW-VC-0910 | 98.6d | 0d | Concrete Mason [78 h]; Common Labor / Helper [62.4 h]; Finishing Work Crew [52 h]; Driver - Conc. Transit Mixers [26 h]; Operator - Concrete Pump [26 h] | 3,431.79 | 0 | 0 | 0.0040086961 | 6 | RPI - CONS | Z2 | PW | MECH | 1.3.3.30 | CONS | CONS | ZONE-3 | ROAD-3 | MECH | SEA-W |
| CON-Z3-UT-SW-VC-0940 |  | Formwork removal and concrete patching | 1.6d | 2017-04-19 | 2017-04-20 | CON-Z3-UT-SW-VC-0930 | 98.6d | 0d | Scaffolder [26 h]; Finishing Work Crew [52 h]; Shuttering Carpenter [78 h] | 686.36 | 0 | 0 | 0.0015418111 | 6 | RPI - CONS | Z2 | PW | MECH | 1.3.3.30 | CONS | CONS | ZONE-3 | ROAD-3 | MECH | SEA-W |
| CON-Z3-UT-SW-VC-0960 |  | Concrete Supports | 0.8d | 2017-04-20 | 2017-04-22 | CON-Z3-UT-SW-VC-0940 | 98.6d | 0d | Shuttering Carpenter [26 h]; Concrete Mason [26 h]; Common Labor / Helper [26 h] | 1,029.54 | 0 | 0 | 0.000616716 | 6 | RPI - CONS | Z2 | PW | MECH | 1.3.3.30 | CONS | CONS | ZONE-3 | ROAD-3 | MECH | SEA-W |
| CON-Z3-UT-SW-VC-0950 |  | Installation of Valves / Pipe Connections / Closing of Openings | 3.2d | 2017-04-22 | 2017-04-25 | CON-Z3-UT-SW-VC-0960 | 98.6d | 0d | Shuttering Carpenter [160 h]; Concrete Mason [160 h]; Common Labor / Helper [26 h]; RTR Pipe Crew [160 h] | 6,863.57 | 0 | 0 | 0.0055505071 | 6 | RPI - CONS | Z2 | PW | MECH | 1.3.3.30 | CONS | CONS | ZONE-3 | ROAD-3 | MECH | SEA-W |
| CON-Z3-UT-SW-VC-0970 |  | Damp Proof Coating | 0.8d | 2017-04-25 | 2017-04-26 | CON-Z3-UT-SW-VC-0940, CON-Z3-UT-SW-VC-0950 | 98.6d | 0d | Painter [52 h]; Water Proofing Crew [52 h] | 686.36 | 0 | 0 | 0.0015418111 | 6 | RPI - CONS | Z2 | PW | MECH | 1.3.3.30 | CONS | CONS | ZONE-3 | ROAD-3 | MECH | SEA-W |
| CON-Z3-UT-SW-VC-0980 |  | Backfilling & Compaction | 4d | 2017-04-26 | 2017-05-01 | CON-Z3-UT-SW-VC-0970 | 98.6d | 0d | Common Labor / Helper [312 h]; Driver - Dump Truck [52 h]; Operator - Bobcat [52 h]; Operator - Roller-Compactor (2~10 Ton) [52 h]; Driver - Water Tanker [52 h]; Operator - JCB [52 h]; Bobcat [56 h]; Plate Compactor [56 h]; Vibrators [56 h]; Water Tanker [56 h]; JCB [56 h] | 3,431.79 | 0 | 0 | 0.0037003381 | 6 | RPI - CONS | Z2 | PW | MECH | 1.3.3.30 | CONS | CONS | ZONE-3 | ROAD-3 | MECH | SEA-W |
| CON-Z3-UT-SW-VC-0990 |  | Installation of Roof Slab, Manhole Cover, Accessories & Finishes | 5.6d | 2017-05-07 | 2017-05-13 | CON-Z3-UT-SW-VC-0980 FS+4.8d, CON-Z3-UT-SW-VC-8260 SS | 98.6d | 1.8d | Common Labor / Helper [52 h]; Finishing Work Crew [52 h] | 5,147.68 | 0 | 0 | 0.002466885 | 6 | RPI - CONS | Z2 | PW | MECH | 1.3.3.30 | CONS | CONS | ZONE-3 | ROAD-3 | MECH | SEA-W |

Notes:
- CON-Z3-UT-SW-VC-0720: Expenses: (New Expense Item) 1715.89
- CON-Z3-UT-SW-VC-0730: Expenses: (New Expense Item) 1029.54
- CON-Z3-UT-SW-VC-0760: Expenses: (New Expense Item) 1715.89
- CON-Z3-UT-SW-VC-0740: Expenses: (New Expense Item) 1715.89
- CON-Z3-UT-SW-VC-0750: Expenses: (New Expense Item) 1715.89
- CON-Z3-UT-SW-VC-0780: Expenses: (New Expense Item) 3431.79
- CON-Z3-UT-SW-VC-0770: Expenses: (New Expense Item) 1715.89
- CON-Z3-UT-SW-VC-0790: Expenses: (New Expense Item) 3431.79
- CON-Z3-UT-SW-VC-0800: Expenses: (New Expense Item) 686.36
- CON-Z3-UT-SW-VC-0820: Expenses: (New Expense Item) 1029.54
- CON-Z3-UT-SW-VC-0810: Expenses: (New Expense Item) 5147.68
- CON-Z3-UT-SW-VC-8240: Expenses: (New Expense Item) 2402.25
- CON-Z3-UT-SW-VC-8250: Expenses: (New Expense Item) 3431.79
- CON-Z3-UT-SW-VC-0830: Expenses: (New Expense Item) 686.36
- CON-Z3-UT-SW-VC-0840: Expenses: (New Expense Item) 1715.89
- CON-Z3-UT-SW-VC-8260: Expenses: (New Expense Item) 2745.43
- CON-Z3-UT-SW-VC-0860: Expenses: (New Expense Item) 1715.89
- CON-Z3-UT-SW-VC-0870: Expenses: (New Expense Item) 1029.54
- CON-Z3-UT-SW-VC-0900: Expenses: (New Expense Item) 1715.89
- CON-Z3-UT-SW-VC-0880: Expenses: (New Expense Item) 1715.89
- CON-Z3-UT-SW-VC-0890: Expenses: (New Expense Item) 1715.89
- CON-Z3-UT-SW-VC-0920: Expenses: (New Expense Item) 3431.79
- CON-Z3-UT-SW-VC-0910: Expenses: (New Expense Item) 1715.89
- CON-Z3-UT-SW-VC-0930: Expenses: (New Expense Item) 3431.79
- CON-Z3-UT-SW-VC-0940: Expenses: (New Expense Item) 686.36
- CON-Z3-UT-SW-VC-0960: Expenses: (New Expense Item) 1029.54
- CON-Z3-UT-SW-VC-0950: Expenses: (New Expense Item) 6863.57
- CON-Z3-UT-SW-VC-0970: Expenses: (New Expense Item) 686.36
- CON-Z3-UT-SW-VC-0980: Expenses: (New Expense Item) 3431.79
- CON-Z3-UT-SW-VC-0990: Expenses: (New Expense Item) 5147.68

| ID | WBS | Activity | Duration | Start | Finish | Predecessors | Total float | Free float | Resources | Cost | Activity Wt% | Weight % | Cost Wt | RPI - PHASE | RPI - CONSTRUCTION | RPI - ZONES | RPI - UTILITY NETWORKS | RPI - TYPE OF WORK | RPI_P2 - BOQ ITEMS | RPI_P2 - CONSTRUCTION | RPI_P2 - PHASE | RPI_P2 - ZONES | RPI_P2 - AREAS | RPI_P2 - DISCIPLINE / WORK TYPE | RPI_P2 - UTILITY NETWORK |
| --- | --- | --- | --- | --- | --- | --- | --- | --- | --- | --- | --- | --- | --- | --- | --- | --- | --- | --- | --- | --- | --- | --- | --- | --- | --- |
|  | 7 | **Chamber - VB-NCL-12 at Road 3** |  | 2017-04-11 | 2017-05-14 |  |  |  |  |  |  |  |  |  |  |  |  |  |  |  |  |  |  |  |  |
| CON-Z3-UT-SW-VC-1000 |  | Excavation and Compaction | 1.6d | 2017-04-11 | 2017-04-12 | CON-Z3-UT-SW-VC-0860 FS+5d | 30.8d | 0d | Operator - Excavator [26 h] | 1,715.89 | 0 | 0 | 0.0030836221 | 6 | RPI - CONS | Z2 | PW | MECH | 1.3.3.30 | CONS | CONS | ZONE-3 | ROAD-3 | MECH | SEA-W |
| CON-Z3-UT-SW-VC-1010 |  | Lean concrete | 0.8d | 2017-04-12 | 2017-04-13 | CON-Z3-UT-SW-VC-1000 | 96.8d | 0d | Concrete Mason [52 h]; Driver - Conc. Transit Mixers [26 h]; Operator - Concrete Pump [26 h] | 1,029.54 | 0 | 0 | 0.0003088871 | 6 | RPI - CONS | Z2 | PW | MECH | 1.3.3.30 | CONS | CONS | ZONE-3 | ROAD-3 | MECH | SEA-W |
| CON-Z3-UT-SW-VC-1040 |  | Formwork for Base Slab | 0.8d | 2017-04-13 | 2017-04-15 | CON-Z3-UT-SW-VC-1010 | 96.8d | 0d | Shuttering Carpenter [78 h]; Common Labor / Helper [52 h] | 1,715.89 | 0 | 0 | 0.000308358 | 6 | RPI - CONS | Z2 | PW | MECH | 1.3.3.30 | CONS | CONS | ZONE-3 | ROAD-3 | MECH | SEA-W |
| CON-Z3-UT-SW-VC-1020 |  | Fabrication & installation of Rebar for Base Slab | 4d | 2017-04-15 | 2017-04-19 | CON-Z3-UT-SW-VC-1040 | 96.8d | 0d | Steel Fixer [480 h] | 1,715.89 | 0 | 0 | 0.0015418111 | 6 | RPI - CONS | Z2 | PW | MECH | 1.3.3.30 | CONS | CONS | ZONE-3 | ROAD-3 | MECH | SEA-W |
| CON-Z3-UT-SW-VC-1030 |  | Fabrication & installation of Rebar for Side walls | 4d | 2017-04-19 | 2017-04-24 | CON-Z3-UT-SW-VC-1020 | 96.8d | 0d | Steel Fixer [480 h] | 1,715.89 | 0 | 0 | 0.0030836221 | 6 | RPI - CONS | Z2 | PW | MECH | 1.3.3.30 | CONS | CONS | ZONE-3 | ROAD-3 | MECH | SEA-W |
| CON-Z3-UT-SW-VC-1060 |  | Formwork for side walls | 4d | 2017-04-20 | 2017-04-25 | CON-Z3-UT-SW-VC-1030 SS+0.8d | 96.8d | 0d | Shuttering Carpenter [78 h]; Common Labor / Helper [26 h]; Scaffolder [52 h] | 3,431.79 | 0 | 0 | 0.0015418111 | 6 | RPI - CONS | Z2 | PW | MECH | 1.3.3.30 | CONS | CONS | ZONE-3 | ROAD-3 | MECH | SEA-W |
| CON-Z3-UT-SW-VC-1050 |  | Concrete pouring for base slab | 0.8d | 2017-04-25 | 2017-04-25 | CON-Z3-UT-SW-VC-1060 | 96.8d | 0d | Concrete Mason [78 h]; Common Labor / Helper [26 h]; Finishing Work Crew [52 h]; Driver - Conc. Transit Mixers [26 h]; Operator - Concrete Pump [26 h] | 1,715.89 | 0 | 0 | 0.0015418111 | 6 | RPI - CONS | Z2 | PW | MECH | 1.3.3.30 | CONS | CONS | ZONE-3 | ROAD-3 | MECH | SEA-W |
| CON-Z3-UT-SW-VC-1070 |  | Concrete pouring for Side Wall | 0.8d | 2017-04-26 | 2017-04-26 | CON-Z3-UT-SW-VC-1050 | 96.8d | 0d | Concrete Mason [78 h]; Common Labor / Helper [26 h]; Finishing Work Crew [52 h]; Driver - Conc. Transit Mixers [26 h]; Operator - Concrete Pump [26 h] | 3,431.79 | 0 | 0 | 0.0040086961 | 6 | RPI - CONS | Z2 | PW | MECH | 1.3.3.30 | CONS | CONS | ZONE-3 | ROAD-3 | MECH | SEA-W |
| CON-Z3-UT-SW-VC-1080 |  | Formwork removal and concrete patching | 1.6d | 2017-04-26 | 2017-04-29 | CON-Z3-UT-SW-VC-1070 | 96.8d | 0d | Shuttering Carpenter [78 h]; Scaffolder [26 h]; Finishing Work Crew [52 h] | 686.36 | 0 | 0 | 0.0015418111 | 6 | RPI - CONS | Z2 | PW | MECH | 1.3.3.30 | CONS | CONS | ZONE-3 | ROAD-3 | MECH | SEA-W |
| CON-Z3-UT-SW-VC-1100 |  | Concrete Supports | 0.8d | 2017-04-29 | 2017-04-30 | CON-Z3-UT-SW-VC-1080 | 96.8d | 0d | Shuttering Carpenter [26 h]; Concrete Mason [26 h]; Common Labor / Helper [26 h] | 1,029.54 | 0 | 0 | 0.000616716 | 6 | RPI - CONS | Z2 | PW | MECH | 1.3.3.30 | CONS | CONS | ZONE-3 | ROAD-3 | MECH | SEA-W |
| CON-Z3-UT-SW-VC-1090 |  | Installation of Pipe Connections / Closing of Openings | 3.2d | 2017-04-30 | 2017-05-03 | CON-Z3-UT-SW-VC-1100 | 96.8d | 0d | Shuttering Carpenter [26 h]; Concrete Mason [26 h]; Plumber [26 h]; Common Labor / Helper [26 h] | 5,147.68 | 0 | 0 | 0.0055505071 | 6 | RPI - CONS | Z2 | PW | MECH | 1.3.3.30 | CONS | CONS | ZONE-3 | ROAD-3 | MECH | SEA-W |
| CON-Z3-UT-SW-VC-8270 |  | Installation of Dismantling joints | 2.4d | 2017-04-30 | 2017-05-02 | CON-Z3-UT-SW-VC-1090 SS | 98.4d | 0d | Common Labor / Helper [26 h]; RTR Pipe Crew [26 h] | 2,402.25 |  |  |  |  |  |  |  |  | 1.3.3.30 | CONS | CONS | ZONE-3 | ROAD-3 | MECH | SEA-W |
| CON-Z3-UT-SW-VC-8280 |  | Installation of Valves | 4d | 2017-05-02 | 2017-05-07 | CON-Z3-UT-SW-VC-8270 | 98.4d | 1.6d | Common Labor / Helper [26 h]; RTR Pipe Crew [26 h] | 3,431.79 |  |  |  |  |  |  |  |  | 1.3.3.30 | CONS | CONS | ZONE-3 | ROAD-3 | MECH | SEA-W |
| CON-Z3-UT-SW-VC-1110 |  | Damp Proof Coating | 0.8d | 2017-05-03 | 2017-05-04 | CON-Z3-UT-SW-VC-1080, CON-Z3-UT-SW-VC-1090 | 96.8d | 0d | Painter [52 h]; Water Proofing Crew [52 h] | 686.36 | 0 | 0 | 0.0015418111 | 6 | RPI - CONS | Z2 | PW | MECH | 1.3.3.30 | CONS | CONS | ZONE-3 | ROAD-3 | MECH | SEA-W |
| CON-Z3-UT-SW-VC-1120 |  | Backfilling & Compaction | 4d | 2017-05-04 | 2017-05-09 | CON-Z3-UT-SW-VC-1110 | 96.8d | 0d | Common Labor / Helper [52 h]; Driver - Dump Truck [26 h]; Operator - Bobcat [26 h]; Operator - Roller-Compactor (2~10 Ton) [26 h]; Driver - Water Tanker [26 h]; Operator - JCB [26 h]; Bobcat [28 h]; Plate Compactor [28 h]; Vibrators [28 h]; Water Tanker [28 h]; JCB [28 h] | 1,715.89 | 0 | 0 | 0.0037003381 | 6 | RPI - CONS | Z2 | PW | MECH | 1.3.3.30 | CONS | CONS | ZONE-3 | ROAD-3 | MECH | SEA-W |
| CON-Z3-UT-SW-VC-8290 |  | Installation of Roof Slab, Manhole Cover, Accessories & Finishes | 4d | 2017-05-09 | 2017-05-14 | CON-Z3-UT-SW-VC-1120, CON-Z3-UT-SW-VC-8280, CON-Z3-UT-SW-VC-0990 SS | 96.8d | 6.6d | Common Labor / Helper [52 h]; Finishing Work Crew [52 h] | 2,745.43 |  |  |  |  |  |  |  |  | 1.3.3.30 | CONS | CONS | ZONE-3 | ROAD-3 | MECH | SEA-W |
|  | 8 | **Chamber - VB-NCL-11 at Road 3** |  | 2017-04-18 | 2017-05-21 |  |  |  |  |  |  |  |  |  |  |  |  |  |  |  |  |  |  |  |  |
| CON-Z3-UT-SW-VC-1140 |  | Excavation and Compaction | 1.6d | 2017-04-18 | 2017-04-20 | CON-Z3-UT-SW-VC-1000 FS+5d | 30.8d | 0d | Operator - Excavator [26 h] | 1,715.89 | 0 | 0 | 0.0030836221 | 6 | RPI - CONS | Z2 | PW | MECH | 1.3.3.30 | CONS | CONS | ZONE-3 | ROAD-3 | MECH | SEA-W |
| CON-Z3-UT-SW-VC-1150 |  | Lean concrete | 0.8d | 2017-04-20 | 2017-04-22 | CON-Z3-UT-SW-VC-1140 | 90.2d | 0d | Concrete Mason [52 h]; Driver - Conc. Transit Mixers [26 h]; Operator - Concrete Pump [26 h] | 1,029.54 | 0 | 0 | 0.0003088871 | 6 | RPI - CONS | Z2 | PW | MECH | 1.3.3.30 | CONS | CONS | ZONE-3 | ROAD-3 | MECH | SEA-W |
| CON-Z3-UT-SW-VC-1180 |  | Formwork for Base Slab | 0.8d | 2017-04-22 | 2017-04-22 | CON-Z3-UT-SW-VC-1150 | 90.2d | 0d | Shuttering Carpenter [78 h]; Common Labor / Helper [52 h] | 1,715.89 | 0 | 0 | 0.000308358 | 6 | RPI - CONS | Z2 | PW | MECH | 1.3.3.30 | CONS | CONS | ZONE-3 | ROAD-3 | MECH | SEA-W |
| CON-Z3-UT-SW-VC-1160 |  | Fabrication & installation of Rebar for Base Slab | 4d | 2017-04-23 | 2017-04-26 | CON-Z3-UT-SW-VC-1180 | 90.2d | 0d | Steel Fixer [320 h] | 1,715.89 | 0 | 0 | 0.0015418111 | 6 | RPI - CONS | Z2 | PW | MECH | 1.3.3.30 | CONS | CONS | ZONE-3 | ROAD-3 | MECH | SEA-W |
| CON-Z3-UT-SW-VC-1170 |  | Fabrication & installation of Rebar for Side walls | 4d | 2017-04-27 | 2017-05-01 | CON-Z3-UT-SW-VC-1160 | 90.2d | 0d | Steel Fixer [320 h] | 1,715.89 | 0 | 0 | 0.0030836221 | 6 | RPI - CONS | Z2 | PW | MECH | 1.3.3.30 | CONS | CONS | ZONE-3 | ROAD-3 | MECH | SEA-W |
| CON-Z3-UT-SW-VC-1200 |  | Formwork for side walls | 4d | 2017-04-27 | 2017-05-02 | CON-Z3-UT-SW-VC-1170 SS+0.8d | 90.2d | 0d | Shuttering Carpenter [78 h]; Common Labor / Helper [26 h]; Scaffolder [52 h] | 3,431.79 | 0 | 0 | 0.0015418111 | 6 | RPI - CONS | Z2 | PW | MECH | 1.3.3.30 | CONS | CONS | ZONE-3 | ROAD-3 | MECH | SEA-W |
| CON-Z3-UT-SW-VC-1190 |  | Concrete pouring for base slab | 0.8d | 2017-05-02 | 2017-05-03 | CON-Z3-UT-SW-VC-1200 | 90.2d | 0d | Concrete Mason [78 h]; Common Labor / Helper [26 h]; Finishing Work Crew [52 h]; Driver - Conc. Transit Mixers [26 h]; Operator - Concrete Pump [26 h] | 1,715.89 | 0 | 0 | 0.0015418111 | 6 | RPI - CONS | Z2 | PW | MECH | 1.3.3.30 | CONS | CONS | ZONE-3 | ROAD-3 | MECH | SEA-W |
| CON-Z3-UT-SW-VC-1210 |  | Concrete pouring for Side Wall | 0.8d | 2017-05-03 | 2017-05-04 | CON-Z3-UT-SW-VC-1190 | 90.2d | 0d | Concrete Mason [78 h]; Common Labor / Helper [26 h]; Finishing Work Crew [52 h]; Driver - Conc. Transit Mixers [26 h]; Operator - Concrete Pump [26 h] | 3,431.79 | 0 | 0 | 0.0040086961 | 6 | RPI - CONS | Z2 | PW | MECH | 1.3.3.30 | CONS | CONS | ZONE-3 | ROAD-3 | MECH | SEA-W |
| CON-Z3-UT-SW-VC-1220 |  | Formwork removal and concrete patching | 1.6d | 2017-05-04 | 2017-05-06 | CON-Z3-UT-SW-VC-1210 | 90.2d | 0d | Shuttering Carpenter [78 h]; Scaffolder [26 h]; Finishing Work Crew [52 h] | 686.36 | 0 | 0 | 0.0015418111 | 6 | RPI - CONS | Z2 | PW | MECH | 1.3.3.30 | CONS | CONS | ZONE-3 | ROAD-3 | MECH | SEA-W |
| CON-Z3-UT-SW-VC-1240 |  | Concrete Supports | 0.8d | 2017-05-07 | 2017-05-07 | CON-Z3-UT-SW-VC-1220 | 90.2d | 0d | Shuttering Carpenter [26 h]; Concrete Mason [26 h]; Common Labor / Helper [26 h] | 1,029.54 | 0 | 0 | 0.000616716 | 6 | RPI - CONS | Z2 | PW | MECH | 1.3.3.30 | CONS | CONS | ZONE-3 | ROAD-3 | MECH | SEA-W |
| CON-Z3-UT-SW-VC-1230 |  | Installation of Pipe Connections / Closing of Openings | 3.2d | 2017-05-07 | 2017-05-10 | CON-Z3-UT-SW-VC-1240 | 90.2d | 0d | Shuttering Carpenter [26 h]; Concrete Mason [26 h]; Plumber [26 h]; Common Labor / Helper [26 h] | 5,147.68 | 0 | 0 | 0.0055505071 | 6 | RPI - CONS | Z2 | PW | MECH | 1.3.3.30 | CONS | CONS | ZONE-3 | ROAD-3 | MECH | SEA-W |
| CON-Z3-UT-SW-VC-8300 |  | Installation of Dismantling joints | 2.4d | 2017-05-07 | 2017-05-10 | CON-Z3-UT-SW-VC-1230 SS | 91.8d | 0d | Common Labor / Helper [26 h]; RTR Pipe Crew [26 h] | 2,402.25 |  |  |  |  |  |  |  |  | 1.3.3.30 | CONS | CONS | ZONE-3 | ROAD-3 | MECH | SEA-W |
| CON-Z3-UT-SW-VC-8310 |  | Installation of Valves | 4d | 2017-05-10 | 2017-05-15 | CON-Z3-UT-SW-VC-8300 | 91.8d | 1.6d | Common Labor / Helper [26 h]; RTR Pipe Crew [26 h] | 3,431.79 |  |  |  |  |  |  |  |  | 1.3.3.30 | CONS | CONS | ZONE-3 | ROAD-3 | MECH | SEA-W |
| CON-Z3-UT-SW-VC-1250 |  | Damp Proof Coating | 0.8d | 2017-05-11 | 2017-05-11 | CON-Z3-UT-SW-VC-1230, CON-Z3-UT-SW-VC-1220 | 90.2d | 0d | Painter [52 h]; Water Proofing Crew [52 h] | 686.36 | 0 | 0 | 0.0015418111 | 6 | RPI - CONS | Z2 | PW | MECH | 1.3.3.30 | CONS | CONS | ZONE-3 | ROAD-3 | MECH | SEA-W |
| CON-Z3-UT-SW-VC-1260 |  | Backfilling & Compaction | 4d | 2017-05-11 | 2017-05-16 | CON-Z3-UT-SW-VC-1250 | 90.2d | 0d | Common Labor / Helper [52 h]; Driver - Dump Truck [26 h]; Operator - Bobcat [26 h]; Operator - Roller-Compactor (2~10 Ton) [26 h]; Driver - Water Tanker [26 h]; Operator - JCB [26 h]; Bobcat [28 h]; Plate Compactor [28 h]; Vibrators [28 h]; Water Tanker [28 h]; JCB [28 h] | 1,715.89 | 0 | 0 | 0.0037003381 | 6 | RPI - CONS | Z2 | PW | MECH | 1.3.3.30 | CONS | CONS | ZONE-3 | ROAD-3 | MECH | SEA-W |
| CON-Z3-UT-SW-VC-8320 |  | Installation of Roof Slab, Manhole Cover, Accessories & Finishes | 4d | 2017-05-16 | 2017-05-21 | CON-Z3-UT-SW-VC-8310, CON-Z3-UT-SW-VC-8290 SS, CON-Z3-UT-SW-VC-1260 | 90.2d | 6.6d | Common Labor / Helper [52 h]; Finishing Work Crew [52 h] | 2,745.43 |  |  |  |  |  |  |  |  | 1.3.3.30 | CONS | CONS | ZONE-3 | ROAD-3 | MECH | SEA-W |

Notes:
- CON-Z3-UT-SW-VC-1000: Expenses: (New Expense Item) 1715.89
- CON-Z3-UT-SW-VC-1010: Expenses: (New Expense Item) 1029.54
- CON-Z3-UT-SW-VC-1040: Expenses: (New Expense Item) 1715.89
- CON-Z3-UT-SW-VC-1020: Expenses: (New Expense Item) 1715.89
- CON-Z3-UT-SW-VC-1030: Expenses: (New Expense Item) 1715.89
- CON-Z3-UT-SW-VC-1060: Expenses: (New Expense Item) 3431.79
- CON-Z3-UT-SW-VC-1050: Expenses: (New Expense Item) 1715.89
- CON-Z3-UT-SW-VC-1070: Expenses: (New Expense Item) 3431.79
- CON-Z3-UT-SW-VC-1080: Expenses: (New Expense Item) 686.36
- CON-Z3-UT-SW-VC-1100: Expenses: (New Expense Item) 1029.54
- CON-Z3-UT-SW-VC-1090: Expenses: (New Expense Item) 5147.68
- CON-Z3-UT-SW-VC-8270: Expenses: (New Expense Item) 2402.25
- CON-Z3-UT-SW-VC-8280: Expenses: (New Expense Item) 3431.79
- CON-Z3-UT-SW-VC-1110: Expenses: (New Expense Item) 686.36
- CON-Z3-UT-SW-VC-1120: Expenses: (New Expense Item) 1715.89
- CON-Z3-UT-SW-VC-8290: Expenses: (New Expense Item) 2745.43
- CON-Z3-UT-SW-VC-1140: Expenses: (New Expense Item) 1715.89
- CON-Z3-UT-SW-VC-1150: Expenses: (New Expense Item) 1029.54
- CON-Z3-UT-SW-VC-1180: Expenses: (New Expense Item) 1715.89
- CON-Z3-UT-SW-VC-1160: Expenses: (New Expense Item) 1715.89
- CON-Z3-UT-SW-VC-1170: Expenses: (New Expense Item) 1715.89
- CON-Z3-UT-SW-VC-1200: Expenses: (New Expense Item) 3431.79
- CON-Z3-UT-SW-VC-1190: Expenses: (New Expense Item) 1715.89
- CON-Z3-UT-SW-VC-1210: Expenses: (New Expense Item) 3431.79
- CON-Z3-UT-SW-VC-1220: Expenses: (New Expense Item) 686.36
- CON-Z3-UT-SW-VC-1240: Expenses: (New Expense Item) 1029.54
- CON-Z3-UT-SW-VC-1230: Expenses: (New Expense Item) 5147.68
- CON-Z3-UT-SW-VC-8300: Expenses: (New Expense Item) 2402.25
- CON-Z3-UT-SW-VC-8310: Expenses: (New Expense Item) 3431.79
- CON-Z3-UT-SW-VC-1250: Expenses: (New Expense Item) 686.36
- CON-Z3-UT-SW-VC-1260: Expenses: (New Expense Item) 1715.89
- CON-Z3-UT-SW-VC-8320: Expenses: (New Expense Item) 2745.43

| ID | WBS | Activity | Duration | Start | Finish | Predecessors | Total float | Free float | Resources | Cost | Activity Wt% | Weight % | Cost Wt | RPI - PHASE | RPI - CONSTRUCTION | RPI - ZONES | RPI - UTILITY NETWORKS | RPI - TYPE OF WORK | RPI_P2 - BOQ ITEMS | RPI_P2 - CONSTRUCTION | RPI_P2 - PHASE | RPI_P2 - ZONES | RPI_P2 - AREAS | RPI_P2 - DISCIPLINE / WORK TYPE | RPI_P2 - UTILITY NETWORK |
| --- | --- | --- | --- | --- | --- | --- | --- | --- | --- | --- | --- | --- | --- | --- | --- | --- | --- | --- | --- | --- | --- | --- | --- | --- | --- |
|  | 9 | **Chamber - VB-NCL-09 at Road 3** |  | 2017-04-26 | 2017-05-29 |  |  |  |  |  |  |  |  |  |  |  |  |  |  |  |  |  |  |  |  |
| CON-Z3-UT-SW-VC-1280 |  | Excavation and Compaction | 1.6d | 2017-04-26 | 2017-04-27 | CON-Z3-UT-SW-VC-1140 FS+5d | 30.8d | 0d | Operator - Excavator [20.8 h]; Excavator [22.4 h]; Common Labor / Helper [124.8 h] | 1,715.89 | 0 | 0 | 0.0030836221 | 6 | RPI - CONS | Z2 | PW | MECH | 1.3.3.30 | CONS | CONS | ZONE-3 | ROAD-3 | MECH | SEA-W |
| CON-Z3-UT-SW-VC-1290 |  | Lean concrete | 0.8d | 2017-04-29 | 2017-04-29 | CON-Z3-UT-SW-VC-1280 | 83.6d | 0d | Concrete Mason [52 h]; Driver - Conc. Transit Mixers [26 h]; Operator - Concrete Pump [26 h] | 1,029.54 | 0 | 0 | 0.0003088871 | 6 | RPI - CONS | Z2 | PW | MECH | 1.3.3.30 | CONS | CONS | ZONE-3 | ROAD-3 | MECH | SEA-W |
| CON-Z3-UT-SW-VC-1320 |  | Formwork for Base Slab | 0.8d | 2017-04-29 | 2017-04-30 | CON-Z3-UT-SW-VC-1290 | 83.6d | 0d | Shuttering Carpenter [78 h]; Common Labor / Helper [52 h] | 1,715.89 | 0 | 0 | 0.000308358 | 6 | RPI - CONS | Z2 | PW | MECH | 1.3.3.30 | CONS | CONS | ZONE-3 | ROAD-3 | MECH | SEA-W |
| CON-Z3-UT-SW-VC-1300 |  | Fabrication & installation of Rebar for Base Slab | 4d | 2017-04-30 | 2017-05-04 | CON-Z3-UT-SW-VC-1320 | 83.6d | 0d | Steel Fixer [78 h] | 1,715.89 | 0 | 0 | 0.0015418111 | 6 | RPI - CONS | Z2 | PW | MECH | 1.3.3.30 | CONS | CONS | ZONE-3 | ROAD-3 | MECH | SEA-W |
| CON-Z3-UT-SW-VC-1310 |  | Fabrication & installation of Rebar for Side walls | 4d | 2017-05-04 | 2017-05-09 | CON-Z3-UT-SW-VC-1300 | 83.6d | 0d | Steel Fixer [78 h] | 1,715.89 | 0 | 0 | 0.0030836221 | 6 | RPI - CONS | Z2 | PW | MECH | 1.3.3.30 | CONS | CONS | ZONE-3 | ROAD-3 | MECH | SEA-W |
| CON-Z3-UT-SW-VC-1340 |  | Formwork for side walls | 4d | 2017-05-06 | 2017-05-10 | CON-Z3-UT-SW-VC-1310 SS+0.8d | 83.6d | 0d | Shuttering Carpenter [78 h]; Common Labor / Helper [26 h]; Scaffolder [52 h] | 3,431.79 | 0 | 0 | 0.0015418111 | 6 | RPI - CONS | Z2 | PW | MECH | 1.3.3.30 | CONS | CONS | ZONE-3 | ROAD-3 | MECH | SEA-W |
| CON-Z3-UT-SW-VC-1330 |  | Concrete pouring for base slab | 0.8d | 2017-05-10 | 2017-05-11 | CON-Z3-UT-SW-VC-1340 | 83.6d | 0d | Concrete Mason [78 h]; Common Labor / Helper [26 h]; Finishing Work Crew [52 h]; Driver - Conc. Transit Mixers [26 h]; Operator - Concrete Pump [26 h] | 1,715.89 | 0 | 0 | 0.0015418111 | 6 | RPI - CONS | Z2 | PW | MECH | 1.3.3.30 | CONS | CONS | ZONE-3 | ROAD-3 | MECH | SEA-W |
| CON-Z3-UT-SW-VC-1350 |  | Concrete pouring for Side Wall | 0.8d | 2017-05-11 | 2017-05-11 | CON-Z3-UT-SW-VC-1330 | 83.6d | 0d | Concrete Mason [78 h]; Common Labor / Helper [26 h]; Finishing Work Crew [52 h]; Driver - Conc. Transit Mixers [26 h]; Operator - Concrete Pump [26 h] | 3,431.79 | 0 | 0 | 0.0040086961 | 6 | RPI - CONS | Z2 | PW | MECH | 1.3.3.30 | CONS | CONS | ZONE-3 | ROAD-3 | MECH | SEA-W |
| CON-Z3-UT-SW-VC-1360 |  | Formwork removal and concrete patching | 1.6d | 2017-05-13 | 2017-05-14 | CON-Z3-UT-SW-VC-1350 | 83.6d | 0d | Finishing Work Crew [52 h]; Shuttering Carpenter [78 h]; Scaffolder [26 h] | 686.36 | 0 | 0 | 0.0015418111 | 6 | RPI - CONS | Z2 | PW | MECH | 1.3.3.30 | CONS | CONS | ZONE-3 | ROAD-3 | MECH | SEA-W |
| CON-Z3-UT-SW-VC-1380 |  | Concrete Supports | 0.8d | 2017-05-14 | 2017-05-15 | CON-Z3-UT-SW-VC-1360 | 83.6d | 0d | Shuttering Carpenter [26 h]; Concrete Mason [26 h]; Common Labor / Helper [26 h] | 1,029.54 | 0 | 0 | 0.000616716 | 6 | RPI - CONS | Z2 | PW | MECH | 1.3.3.30 | CONS | CONS | ZONE-3 | ROAD-3 | MECH | SEA-W |
| CON-Z3-UT-SW-VC-1370 |  | Installation of Pipe Connections / Closing of Openings | 3.2d | 2017-05-15 | 2017-05-18 | CON-Z3-UT-SW-VC-1380 | 83.6d | 0d | Shuttering Carpenter [26 h]; Concrete Mason [26 h]; Plumber [26 h]; Common Labor / Helper [26 h] | 5,147.68 | 0 | 0 | 0.0055505071 | 6 | RPI - CONS | Z2 | PW | MECH | 1.3.3.30 | CONS | CONS | ZONE-3 | ROAD-3 | MECH | SEA-W |
| CON-Z3-UT-SW-VC-8330 |  | Installation of Dismantling joints | 2.4d | 2017-05-15 | 2017-05-17 | CON-Z3-UT-SW-VC-1370 SS | 85.2d | 0d | Common Labor / Helper [26 h]; RTR Pipe Crew [26 h] | 2,402.25 |  |  |  |  |  |  |  |  | 1.3.3.30 | CONS | CONS | ZONE-3 | ROAD-3 | MECH | SEA-W |
| CON-Z3-UT-SW-VC-8340 |  | Installation of Valves | 4d | 2017-05-17 | 2017-05-22 | CON-Z3-UT-SW-VC-8330 | 85.2d | 1.6d | Common Labor / Helper [26 h]; RTR Pipe Crew [26 h] | 3,431.79 |  |  |  |  |  |  |  |  | 1.3.3.30 | CONS | CONS | ZONE-3 | ROAD-3 | MECH | SEA-W |
| CON-Z3-UT-SW-VC-1390 |  | Damp Proof Coating | 0.8d | 2017-05-18 | 2017-05-20 | CON-Z3-UT-SW-VC-1370, CON-Z3-UT-SW-VC-1360 | 83.6d | 0d | Painter [52 h]; Water Proofing Crew [52 h] | 686.36 | 0 | 0 | 0.0015418111 | 6 | RPI - CONS | Z2 | PW | MECH | 1.3.3.30 | CONS | CONS | ZONE-3 | ROAD-3 | MECH | SEA-W |
| CON-Z3-UT-SW-VC-1400 |  | Backfilling & Compaction | 4d | 2017-05-20 | 2017-05-24 | CON-Z3-UT-SW-VC-1390 | 83.6d | 0d | Common Labor / Helper [52 h]; Driver - Dump Truck [26 h]; Operator - Bobcat [26 h]; Operator - Roller-Compactor (2~10 Ton) [26 h]; Driver - Water Tanker [26 h]; Operator - JCB [26 h]; Bobcat [28 h]; Plate Compactor [28 h]; Vibrators [28 h]; Water Tanker [28 h]; JCB [28 h] | 1,715.89 | 0 | 0 | 0.0037003381 | 6 | RPI - CONS | Z2 | PW | MECH | 1.3.3.30 | CONS | CONS | ZONE-3 | ROAD-3 | MECH | SEA-W |
| CON-Z3-UT-SW-VC-8350 |  | Installation of Roof Slab, Manhole Cover, Accessories & Finishes | 4d | 2017-05-24 | 2017-05-29 | CON-Z3-UT-SW-VC-8340, CON-Z3-UT-SW-VC-1400, CON-Z3-UT-SW-VC-8320 SS | 83.6d | 6.6d | Common Labor / Helper [52 h]; Finishing Work Crew [52 h] | 2,745.43 |  |  |  |  |  |  |  |  | 1.3.3.30 | CONS | CONS | ZONE-3 | ROAD-3 | MECH | SEA-W |
|  | 10 | **Air Release Valve Chamber (AV-7) at Road 3** |  | 2017-05-04 | 2017-06-05 |  |  |  |  |  |  |  |  |  |  |  |  |  |  |  |  |  |  |  |  |
| CON-Z3-UT-SW-VC-1420 |  | Excavation and Compaction | 1.6d | 2017-05-04 | 2017-05-06 | CON-Z3-UT-SW-VC-1280 FS+5d | 30.8d | 0d | Operator - Excavator [26 h] | 1,715.89 | 0 | 0 | 0.0030836221 | 6 | RPI - CONS | Z2 | PW | MECH | 1.3.3.30 | CONS | CONS | ZONE-3 | ROAD-3 | MECH | SEA-W |
| CON-Z3-UT-SW-VC-1430 |  | Lean concrete | 0.8d | 2017-05-06 | 2017-05-07 | CON-Z3-UT-SW-VC-1420 | 77d | 0d | Concrete Mason [52 h]; Driver - Conc. Transit Mixers [26 h]; Operator - Concrete Pump [26 h] | 1,029.54 | 0 | 0 | 0.0003088871 | 6 | RPI - CONS | Z2 | PW | MECH | 1.3.3.30 | CONS | CONS | ZONE-3 | ROAD-3 | MECH | SEA-W |
| CON-Z3-UT-SW-VC-1460 |  | Formwork for Base Slab | 0.8d | 2017-05-07 | 2017-05-08 | CON-Z3-UT-SW-VC-1430 | 77d | 0d | Shuttering Carpenter [78 h]; Common Labor / Helper [52 h] | 1,715.89 | 0 | 0 | 0.000308358 | 6 | RPI - CONS | Z2 | PW | MECH | 1.3.3.30 | CONS | CONS | ZONE-3 | ROAD-3 | MECH | SEA-W |
| CON-Z3-UT-SW-VC-1440 |  | Fabrication & installation of Rebar for Base Slab | 4d | 2017-05-08 | 2017-05-13 | CON-Z3-UT-SW-VC-1460 | 77d | 0d | Steel Fixer [78 h] | 1,715.89 | 0 | 0 | 0.0015418111 | 6 | RPI - CONS | Z2 | PW | MECH | 1.3.3.30 | CONS | CONS | ZONE-3 | ROAD-3 | MECH | SEA-W |
| CON-Z3-UT-SW-VC-1450 |  | Fabrication & installation of Rebar for Side walls | 4d | 2017-05-13 | 2017-05-17 | CON-Z3-UT-SW-VC-1440 | 77d | 0d | Steel Fixer [78 h] | 1,715.89 | 0 | 0 | 0.0030836221 | 6 | RPI - CONS | Z2 | PW | MECH | 1.3.3.30 | CONS | CONS | ZONE-3 | ROAD-3 | MECH | SEA-W |
| CON-Z3-UT-SW-VC-1480 |  | Formwork for side walls | 4d | 2017-05-14 | 2017-05-17 | CON-Z3-UT-SW-VC-1450 SS+0.8d | 77d | 0d | Shuttering Carpenter [78 h]; Common Labor / Helper [26 h]; Scaffolder [52 h] | 3,431.79 | 0 | 0 | 0.0015418111 | 6 | RPI - CONS | Z2 | PW | MECH | 1.3.3.30 | CONS | CONS | ZONE-3 | ROAD-3 | MECH | SEA-W |
| CON-Z3-UT-SW-VC-1470 |  | Concrete pouring for base slab | 0.8d | 2017-05-18 | 2017-05-18 | CON-Z3-UT-SW-VC-1480 | 77d | 0d | Concrete Mason [78 h]; Common Labor / Helper [26 h]; Finishing Work Crew [52 h]; Driver - Conc. Transit Mixers [26 h]; Operator - Concrete Pump [26 h] | 1,715.89 | 0 | 0 | 0.0015418111 | 6 | RPI - CONS | Z2 | PW | MECH | 1.3.3.30 | CONS | CONS | ZONE-3 | ROAD-3 | MECH | SEA-W |
| CON-Z3-UT-SW-VC-1490 |  | Concrete pouring for Side Wall | 0.8d | 2017-05-18 | 2017-05-20 | CON-Z3-UT-SW-VC-1470 | 77d | 0d | Concrete Mason [78 h]; Common Labor / Helper [26 h]; Finishing Work Crew [52 h]; Driver - Conc. Transit Mixers [26 h]; Operator - Concrete Pump [26 h] | 3,431.79 | 0 | 0 | 0.0040086961 | 6 | RPI - CONS | Z2 | PW | MECH | 1.3.3.30 | CONS | CONS | ZONE-3 | ROAD-3 | MECH | SEA-W |
| CON-Z3-UT-SW-VC-1500 |  | Formwork removal and concrete patching | 1.6d | 2017-05-20 | 2017-05-22 | CON-Z3-UT-SW-VC-1490 | 77d | 0d | Shuttering Carpenter [78 h]; Scaffolder [26 h]; Finishing Work Crew [52 h] | 686.36 | 0 | 0 | 0.0015418111 | 6 | RPI - CONS | Z2 | PW | MECH | 1.3.3.30 | CONS | CONS | ZONE-3 | ROAD-3 | MECH | SEA-W |
| CON-Z3-UT-SW-VC-1520 |  | Concrete Supports | 0.8d | 2017-05-22 | 2017-05-22 | CON-Z3-UT-SW-VC-1500 | 77d | 0d | Shuttering Carpenter [26 h]; Concrete Mason [26 h]; Common Labor / Helper [26 h] | 1,029.54 | 0 | 0 | 0.000616716 | 6 | RPI - CONS | Z2 | PW | MECH | 1.3.3.30 | CONS | CONS | ZONE-3 | ROAD-3 | MECH | SEA-W |
| CON-Z3-UT-SW-VC-1510 |  | Installation of Pipe Connections / Closing of Openings | 3.2d | 2017-05-23 | 2017-05-27 | CON-Z3-UT-SW-VC-1520 | 77d | 0d | Shuttering Carpenter [26 h]; Concrete Mason [26 h]; Plumber [26 h]; Common Labor / Helper [26 h] | 5,147.68 | 0 | 0 | 0.0055505071 | 6 | RPI - CONS | Z2 | PW | MECH | 1.3.3.30 | CONS | CONS | ZONE-3 | ROAD-3 | MECH | SEA-W |
| CON-Z3-UT-SW-VC-8090 |  | Installation of Gate valves | 3d | 2017-05-23 | 2017-05-25 | CON-Z3-UT-SW-VC-1510 SS | 79.6d | 0d | Common Labor / Helper [26 h]; RTR Pipe Crew [26 h] | 2,402.25 | 0 | 0 | 0.002466885 | 6 | RPI - CONS | Z2 | PW | MECH | 1.3.3.30 | CONS | CONS | ZONE-3 | ROAD-3 | MECH | SEA-W |
| CON-Z3-UT-SW-VC-8100 |  | Installation of Air Release Valves | 2.4d | 2017-05-27 | 2017-05-29 | CON-Z3-UT-SW-VC-8090 | 79.6d | 2.6d | Common Labor / Helper [26 h]; RTR Pipe Crew [26 h] | 3,431.79 |  |  |  |  |  |  |  |  | 1.3.3.30 | CONS | CONS | ZONE-3 | ROAD-3 | MECH | SEA-W |
| CON-Z3-UT-SW-VC-1530 |  | Damp Proof Coating | 0.8d | 2017-05-27 | 2017-05-27 | CON-Z3-UT-SW-VC-1510, CON-Z3-UT-SW-VC-1500 | 77d | 0d | Painter [52 h]; Water Proofing Crew [52 h] | 686.36 | 0 | 0 | 0.0015418111 | 6 | RPI - CONS | Z2 | PW | MECH | 1.3.3.30 | CONS | CONS | ZONE-3 | ROAD-3 | MECH | SEA-W |
| CON-Z3-UT-SW-VC-1540 |  | Backfilling & Compaction | 4d | 2017-05-28 | 2017-05-31 | CON-Z3-UT-SW-VC-1530 | 77d | 0d | Common Labor / Helper [52 h]; Driver - Dump Truck [26 h]; Operator - Bobcat [26 h]; Operator - Roller-Compactor (2~10 Ton) [26 h]; Driver - Water Tanker [26 h]; Operator - JCB [26 h]; Bobcat [28 h]; Plate Compactor [28 h]; Vibrators [28 h]; Water Tanker [28 h]; JCB [28 h] | 1,715.89 | 0 | 0 | 0.0037003381 | 6 | RPI - CONS | Z2 | PW | MECH | 1.3.3.30 | CONS | CONS | ZONE-3 | ROAD-3 | MECH | SEA-W |
| CON-Z3-UT-SW-VC-8110 |  | Installation of Roof Slab, Manhole Cover, Accessories & Finishes | 4d | 2017-06-01 | 2017-06-05 | CON-Z3-UT-SW-VC-1540, CON-Z3-UT-SW-VC-8100, CON-Z3-UT-SW-VC-8350 SS | 77d | 11.4d | Common Labor / Helper [800 h]; Finishing Work Crew [200 h] | 2,745.43 |  |  |  |  |  |  |  |  | 1.3.3.30 | CONS | CONS | ZONE-3 | ROAD-3 | MECH | SEA-W |

Notes:
- CON-Z3-UT-SW-VC-1280: Expenses: (New Expense Item) 1715.89
- CON-Z3-UT-SW-VC-1290: Expenses: (New Expense Item) 1029.54
- CON-Z3-UT-SW-VC-1320: Expenses: (New Expense Item) 1715.89
- CON-Z3-UT-SW-VC-1300: Expenses: (New Expense Item) 1715.89
- CON-Z3-UT-SW-VC-1310: Expenses: (New Expense Item) 1715.89
- CON-Z3-UT-SW-VC-1340: Expenses: (New Expense Item) 3431.79
- CON-Z3-UT-SW-VC-1330: Expenses: (New Expense Item) 1715.89
- CON-Z3-UT-SW-VC-1350: Expenses: (New Expense Item) 3431.79
- CON-Z3-UT-SW-VC-1360: Expenses: (New Expense Item) 686.36
- CON-Z3-UT-SW-VC-1380: Expenses: (New Expense Item) 1029.54
- CON-Z3-UT-SW-VC-1370: Expenses: (New Expense Item) 5147.68
- CON-Z3-UT-SW-VC-8330: Expenses: (New Expense Item) 2402.25
- CON-Z3-UT-SW-VC-8340: Expenses: (New Expense Item) 3431.79
- CON-Z3-UT-SW-VC-1390: Expenses: (New Expense Item) 686.36
- CON-Z3-UT-SW-VC-1400: Expenses: (New Expense Item) 1715.89
- CON-Z3-UT-SW-VC-8350: Expenses: (New Expense Item) 2745.43
- CON-Z3-UT-SW-VC-1420: Expenses: (New Expense Item) 1715.89
- CON-Z3-UT-SW-VC-1430: Expenses: (New Expense Item) 1029.54
- CON-Z3-UT-SW-VC-1460: Expenses: (New Expense Item) 1715.89
- CON-Z3-UT-SW-VC-1440: Expenses: (New Expense Item) 1715.89
- CON-Z3-UT-SW-VC-1450: Expenses: (New Expense Item) 1715.89
- CON-Z3-UT-SW-VC-1480: Expenses: (New Expense Item) 3431.79
- CON-Z3-UT-SW-VC-1470: Expenses: (New Expense Item) 1715.89
- CON-Z3-UT-SW-VC-1490: Expenses: (New Expense Item) 3431.79
- CON-Z3-UT-SW-VC-1500: Expenses: (New Expense Item) 686.36
- CON-Z3-UT-SW-VC-1520: Expenses: (New Expense Item) 1029.54
- CON-Z3-UT-SW-VC-1510: Expenses: (New Expense Item) 5147.68
- CON-Z3-UT-SW-VC-8090: Expenses: (New Expense Item) 2402.25
- CON-Z3-UT-SW-VC-8100: Expenses: (New Expense Item) 3431.79
- CON-Z3-UT-SW-VC-1530: Expenses: (New Expense Item) 686.36
- CON-Z3-UT-SW-VC-1540: Expenses: (New Expense Item) 1715.89
- CON-Z3-UT-SW-VC-8110: Expenses: (New Expense Item) 2745.43

| ID | WBS | Activity | Duration | Start | Finish | Predecessors | Total float | Free float | Resources | Cost | Activity Wt% | Weight % | Cost Wt | RPI - PHASE | RPI - CONSTRUCTION | RPI - ZONES | RPI - UTILITY NETWORKS | RPI - TYPE OF WORK | RPI_P2 - BOQ ITEMS | RPI_P2 - CONSTRUCTION | RPI_P2 - PHASE | RPI_P2 - ZONES | RPI_P2 - AREAS | RPI_P2 - DISCIPLINE / WORK TYPE | RPI_P2 - UTILITY NETWORK |
| --- | --- | --- | --- | --- | --- | --- | --- | --- | --- | --- | --- | --- | --- | --- | --- | --- | --- | --- | --- | --- | --- | --- | --- | --- | --- |
|  | 13 | **Wash Down Valve Chamber (WDV-3) at Junction of Road3/Road B** |  | 2017-05-11 | 2017-06-20 |  |  |  |  |  |  |  |  |  |  |  |  |  |  |  |  |  |  |  |  |
| CON-Z3-UT-SW-VC-1850 |  | Excavation and Compaction | 1.6d | 2017-05-11 | 2017-05-14 | CON-Z3-UT-SW-VC-1420 FS+5d | 30.8d | 0d | Operator - Excavator [26 h] | 1,715.89 | 0 | 0 | 0.0030836221 | 6 | RPI - CONS | Z2 | PW | MECH | 1.3.3.30 | CONS | CONS | ZONE-3 | ROAD-3 | MECH | SEA-W |
| CON-Z3-UT-SW-VC-1860 |  | Lean concrete | 0.8d | 2017-05-14 | 2017-05-14 | CON-Z3-UT-SW-VC-1850 | 65.6d | 0d | Concrete Mason [52 h]; Driver - Conc. Transit Mixers [26 h]; Operator - Concrete Pump [26 h] | 1,029.54 | 0 | 0 | 0.0003088871 | 6 | RPI - CONS | Z2 | PW | MECH | 1.3.3.30 | CONS | CONS | ZONE-3 | ROAD-3 | MECH | SEA-W |
| CON-Z3-UT-SW-VC-1890 |  | Formwork for Base Slab | 0.8d | 2017-05-15 | 2017-05-15 | CON-Z3-UT-SW-VC-1860 | 65.6d | 0d | Shuttering Carpenter [78 h]; Common Labor / Helper [52 h] | 1,715.89 | 0 | 0 | 0.000308358 | 6 | RPI - CONS | Z2 | PW | MECH | 1.3.3.30 | CONS | CONS | ZONE-3 | ROAD-3 | MECH | SEA-W |
| CON-Z3-UT-SW-VC-1870 |  | Fabrication & installation of Rebar for Base Slab | 4d | 2017-05-15 | 2017-05-20 | CON-Z3-UT-SW-VC-1890 | 65.6d | 0d | Steel Fixer [78 h] | 1,715.89 | 0 | 0 | 0.0015418111 | 6 | RPI - CONS | Z2 | PW | MECH | 1.3.3.30 | CONS | CONS | ZONE-3 | ROAD-3 | MECH | SEA-W |
| CON-Z3-UT-SW-VC-1880 |  | Fabrication & installation of Rebar for Side walls | 4d | 2017-05-20 | 2017-05-24 | CON-Z3-UT-SW-VC-1870 | 65.6d | 0d | Steel Fixer [78 h] | 1,715.89 | 0 | 0 | 0.0030836221 | 6 | RPI - CONS | Z2 | PW | MECH | 1.3.3.30 | CONS | CONS | ZONE-3 | ROAD-3 | MECH | SEA-W |
| CON-Z3-UT-SW-VC-1910 |  | Formwork for side walls | 4d | 2017-05-21 | 2017-05-25 | CON-Z3-UT-SW-VC-1880 SS+0.8d | 65.6d | 0d | Shuttering Carpenter [78 h]; Common Labor / Helper [26 h]; Scaffolder [52 h] | 3,431.79 | 0 | 0 | 0.0015418111 | 6 | RPI - CONS | Z2 | PW | MECH | 1.3.3.30 | CONS | CONS | ZONE-3 | ROAD-3 | MECH | SEA-W |
| CON-Z3-UT-SW-VC-1900 |  | Concrete pouring for base slab | 0.8d | 2017-05-25 | 2017-05-27 | CON-Z3-UT-SW-VC-1910 | 65.6d | 0d | Concrete Mason [78 h]; Common Labor / Helper [26 h]; Finishing Work Crew [52 h]; Driver - Conc. Transit Mixers [26 h]; Operator - Concrete Pump [26 h] | 1,715.89 | 0 | 0 | 0.0015418111 | 6 | RPI - CONS | Z2 | PW | MECH | 1.3.3.30 | CONS | CONS | ZONE-3 | ROAD-3 | MECH | SEA-W |
| CON-Z3-UT-SW-VC-1920 |  | Concrete pouring for Side Wall | 0.8d | 2017-05-27 | 2017-05-28 | CON-Z3-UT-SW-VC-1900 | 65.6d | 0d | Concrete Mason [78 h]; Common Labor / Helper [26 h]; Finishing Work Crew [52 h]; Driver - Conc. Transit Mixers [26 h]; Operator - Concrete Pump [26 h] | 3,431.79 | 0 | 0 | 0.0040086961 | 6 | RPI - CONS | Z2 | PW | MECH | 1.3.3.30 | CONS | CONS | ZONE-3 | ROAD-3 | MECH | SEA-W |
| CON-Z3-UT-SW-VC-1930 |  | Formwork removal and concrete patching | 1.6d | 2017-05-28 | 2017-05-29 | CON-Z3-UT-SW-VC-1920 | 65.6d | 0d | Shuttering Carpenter [78 h]; Scaffolder [26 h]; Finishing Work Crew [52 h] | 686.36 | 0 | 0 | 0.0015418111 | 6 | RPI - CONS | Z2 | PW | MECH | 1.3.3.30 | CONS | CONS | ZONE-3 | ROAD-3 | MECH | SEA-W |
| CON-Z3-UT-SW-VC-1950 |  | Concrete Supports | 0.8d | 2017-05-29 | 2017-05-30 | CON-Z3-UT-SW-VC-1930 | 65.6d | 0d | Shuttering Carpenter [26 h]; Concrete Mason [26 h]; Common Labor / Helper [26 h] | 1,029.54 | 0 | 0 | 0.000616716 | 6 | RPI - CONS | Z2 | PW | MECH | 1.3.3.30 | CONS | CONS | ZONE-3 | ROAD-3 | MECH | SEA-W |
| CON-Z3-UT-SW-VC-1940 |  | Installation of Valves / Pipe Connections / Closing of Openings | 3.2d | 2017-05-30 | 2017-06-03 | CON-Z3-UT-SW-VC-1950 | 65.6d | 0d | Shuttering Carpenter [26 h]; Concrete Mason [26 h]; Common Labor / Helper [26 h]; RTR Pipe Crew [26 h] | 6,863.57 | 0 | 0 | 0.0055505071 | 6 | RPI - CONS | Z2 | PW | MECH | 1.3.3.30 | CONS | CONS | ZONE-3 | ROAD-3 | MECH | SEA-W |
| CON-Z3-UT-SW-VC-1960 |  | Damp Proof Coating | 0.8d | 2017-06-03 | 2017-06-04 | CON-Z3-UT-SW-VC-1940, CON-Z3-UT-SW-VC-1930 | 65.6d | 0d | Painter [8 h]; Water Proofing Crew [8 h] | 686.36 | 0 | 0 | 0.0015418111 | 6 | RPI - CONS | Z2 | PW | MECH | 1.3.3.30 | CONS | CONS | ZONE-3 | ROAD-3 | MECH | SEA-W |
| CON-Z3-UT-SW-VC-1970 |  | Backfilling & Compaction | 4d | 2017-06-04 | 2017-06-08 | CON-Z3-UT-SW-VC-1960 | 65.6d | 0d | Common Labor / Helper [40 h]; Driver - Dump Truck [52 h]; Operator - Bobcat [52 h]; Operator - Roller-Compactor (2~10 Ton) [52 h]; Driver - Water Tanker [52 h]; Operator - JCB [52 h]; Bobcat [56 h]; Plate Compactor [56 h]; Vibrators [56 h]; Water Tanker [56 h]; JCB [56 h] | 3,431.79 | 0 | 0 | 0.0037003381 | 6 | RPI - CONS | Z2 | PW | MECH | 1.3.3.30 | CONS | CONS | ZONE-3 | ROAD-3 | MECH | SEA-W |
| CON-Z3-UT-SW-VC-1980 |  | Installation of Roof Slab, Manhole Cover, Accessories & Finishes | 5.6d | 2017-06-14 | 2017-06-20 | CON-Z3-UT-SW-VC-1970 FS+4.8d, CON-Z3-UT-SW-VC-8110 SS | 65.6d | 1.8d | Common Labor / Helper [56 h]; Finishing Work Crew [56 h] | 5,147.68 | 0 | 0 | 0.002466885 | 6 | RPI - CONS | Z2 | PW | MECH | 1.3.3.30 | CONS | CONS | ZONE-3 | ROAD-3 | MECH | SEA-W |
|  | 14 | **Chamber - VB-NCL-06 at Road 3** |  | 2017-05-20 | 2017-06-21 |  |  |  |  |  |  |  |  |  |  |  |  |  |  |  |  |  |  |  |  |
| CON-Z3-UT-SW-VC-1990 |  | Excavation and Compaction | 1.6d | 2017-05-20 | 2017-05-21 | CON-Z3-UT-SW-VC-1850 FS+5d | 30.8d | 0d | Operator - Excavator [26 h] | 1,715.89 | 0 | 0 | 0.0030836221 | 6 | RPI - CONS | Z2 | PW | MECH | 1.3.3.30 | CONS | CONS | ZONE-3 | ROAD-3 | MECH | SEA-W |
| CON-Z3-UT-SW-VC-2000 |  | Lean concrete | 0.8d | 2017-05-21 | 2017-05-22 | CON-Z3-UT-SW-VC-1990 | 63.8d | 0d | Concrete Mason [52 h]; Driver - Conc. Transit Mixers [26 h]; Operator - Concrete Pump [26 h] | 1,029.54 | 0 | 0 | 0.0003088871 | 6 | RPI - CONS | Z2 | PW | MECH | 1.3.3.30 | CONS | CONS | ZONE-3 | ROAD-3 | MECH | SEA-W |
| CON-Z3-UT-SW-VC-2030 |  | Formwork for Base Slab | 0.8d | 2017-05-22 | 2017-05-23 | CON-Z3-UT-SW-VC-2000 | 63.8d | 0d | Shuttering Carpenter [78 h]; Common Labor / Helper [52 h] | 1,715.89 | 0 | 0 | 0.000308358 | 6 | RPI - CONS | Z2 | PW | MECH | 1.3.3.30 | CONS | CONS | ZONE-3 | ROAD-3 | MECH | SEA-W |
| CON-Z3-UT-SW-VC-2010 |  | Fabrication & installation of Rebar for Base Slab | 4d | 2017-05-23 | 2017-05-28 | CON-Z3-UT-SW-VC-2030 | 63.8d | 0d | Steel Fixer [78 h] | 1,715.89 | 0 | 0 | 0.0015418111 | 6 | RPI - CONS | Z2 | PW | MECH | 1.3.3.30 | CONS | CONS | ZONE-3 | ROAD-3 | MECH | SEA-W |
| CON-Z3-UT-SW-VC-2020 |  | Fabrication & installation of Rebar for Side walls | 4d | 2017-05-28 | 2017-06-01 | CON-Z3-UT-SW-VC-2010 | 63.8d | 0d | Steel Fixer [78 h] | 1,715.89 | 0 | 0 | 0.0030836221 | 6 | RPI - CONS | Z2 | PW | MECH | 1.3.3.30 | CONS | CONS | ZONE-3 | ROAD-3 | MECH | SEA-W |
| CON-Z3-UT-SW-VC-2050 |  | Formwork for side walls | 4d | 2017-05-29 | 2017-06-03 | CON-Z3-UT-SW-VC-2020 SS+0.8d | 63.8d | 0d | Shuttering Carpenter [78 h]; Common Labor / Helper [26 h]; Scaffolder [52 h] | 3,431.79 | 0 | 0 | 0.0015418111 | 6 | RPI - CONS | Z2 | PW | MECH | 1.3.3.30 | CONS | CONS | ZONE-3 | ROAD-3 | MECH | SEA-W |
| CON-Z3-UT-SW-VC-2040 |  | Concrete pouring for base slab | 0.8d | 2017-06-03 | 2017-06-03 | CON-Z3-UT-SW-VC-2050 | 63.8d | 0d | Concrete Mason [8 h]; Common Labor / Helper [8 h]; Finishing Work Crew [52 h]; Driver - Conc. Transit Mixers [26 h]; Operator - Concrete Pump [26 h] | 1,715.89 | 0 | 0 | 0.0015418111 | 6 | RPI - CONS | Z2 | PW | MECH | 1.3.3.30 | CONS | CONS | ZONE-3 | ROAD-3 | MECH | SEA-W |
| CON-Z3-UT-SW-VC-2060 |  | Concrete pouring for Side Wall | 0.8d | 2017-06-04 | 2017-06-04 | CON-Z3-UT-SW-VC-2040 | 63.8d | 0d | Concrete Mason [8 h]; Common Labor / Helper [8 h]; Finishing Work Crew [52 h]; Driver - Conc. Transit Mixers [26 h]; Operator - Concrete Pump [26 h] | 3,431.79 | 0 | 0 | 0.0040086961 | 6 | RPI - CONS | Z2 | PW | MECH | 1.3.3.30 | CONS | CONS | ZONE-3 | ROAD-3 | MECH | SEA-W |
| CON-Z3-UT-SW-VC-2070 |  | Formwork removal and concrete patching | 1.6d | 2017-06-04 | 2017-06-06 | CON-Z3-UT-SW-VC-2060 | 63.8d | 0d | Shuttering Carpenter [16 h]; Scaffolder [16 h]; Finishing Work Crew [16 h] | 686.36 | 0 | 0 | 0.0015418111 | 6 | RPI - CONS | Z2 | PW | MECH | 1.3.3.30 | CONS | CONS | ZONE-3 | ROAD-3 | MECH | SEA-W |
| CON-Z3-UT-SW-VC-2090 |  | Concrete Supports | 0.8d | 2017-06-06 | 2017-06-07 | CON-Z3-UT-SW-VC-2070 | 63.8d | 0d | Shuttering Carpenter [8 h]; Concrete Mason [8 h]; Common Labor / Helper [8 h] | 1,029.54 | 0 | 0 | 0.000616716 | 6 | RPI - CONS | Z2 | PW | MECH | 1.3.3.30 | CONS | CONS | ZONE-3 | ROAD-3 | MECH | SEA-W |
| CON-Z3-UT-SW-VC-2080 |  | Installation of Pipe Connections / Closing of Openings | 3.2d | 2017-06-07 | 2017-06-11 | CON-Z3-UT-SW-VC-2090 | 63.8d | 0d | Shuttering Carpenter [32 h]; Concrete Mason [32 h]; Plumber [32 h]; Common Labor / Helper [32 h] | 5,147.68 | 0 | 0 | 0.0055505071 | 6 | RPI - CONS | Z2 | PW | MECH | 1.3.3.30 | CONS | CONS | ZONE-3 | ROAD-3 | MECH | SEA-W |
| CON-Z3-UT-SW-VC-8360 |  | Installation of Dismantling joints | 2.4d | 2017-06-07 | 2017-06-10 | CON-Z3-UT-SW-VC-2080 SS | 65.4d | 0d | Common Labor / Helper [24 h]; RTR Pipe Crew [360 h]; Plumber [360 h] | 2,402.25 |  |  |  |  |  |  |  |  | 1.3.3.30 | CONS | CONS | ZONE-3 | ROAD-3 | MECH | SEA-W |
| CON-Z3-UT-SW-VC-8370 |  | Installation of Valves | 4d | 2017-06-10 | 2017-06-14 | CON-Z3-UT-SW-VC-8360 | 65.4d | 1.6d | Common Labor / Helper [40 h]; RTR Pipe Crew [200 h]; Plumber [600 h] | 3,431.79 |  |  |  |  |  |  |  |  | 1.3.3.30 | CONS | CONS | ZONE-3 | ROAD-3 | MECH | SEA-W |
| CON-Z3-UT-SW-VC-3000 |  | Damp Proof Coating | 0.8d | 2017-06-11 | 2017-06-12 | CON-Z3-UT-SW-VC-2080, CON-Z3-UT-SW-VC-2070 | 63.8d | 0d | Painter [8 h]; Water Proofing Crew [8 h] | 686.36 | 0 | 0 | 0.0015418111 | 6 | RPI - CONS | Z2 | PW | MECH | 1.3.3.30 | CONS | CONS | ZONE-3 | ROAD-3 | MECH | SEA-W |
| CON-Z3-UT-SW-VC-3010 |  | Backfilling & Compaction | 4d | 2017-06-12 | 2017-06-17 | CON-Z3-UT-SW-VC-3000 | 63.8d | 0d | Common Labor / Helper [40 h]; Driver - Dump Truck [52 h]; Operator - Bobcat [52 h]; Operator - Roller-Compactor (2~10 Ton) [52 h]; Driver - Water Tanker [52 h]; Operator - JCB [52 h]; Bobcat [56 h]; Plate Compactor [56 h]; Vibrators [56 h]; Water Tanker [56 h]; JCB [56 h] | 1,715.89 | 0 | 0 | 0.0037003381 | 6 | RPI - CONS | Z2 | PW | MECH | 1.3.3.30 | CONS | CONS | ZONE-3 | ROAD-3 | MECH | SEA-W |
| CON-Z3-UT-SW-VC-8380 |  | Installation of Roof Slab, Manhole Cover, Accessories & Finishes | 4d | 2017-06-17 | 2017-06-21 | CON-Z3-UT-SW-VC-8370, CON-Z3-UT-SW-VC-1980 SS, CON-Z3-UT-SW-VC-3010 | 63.8d | 6.6d | Common Labor / Helper [40 h]; Finishing Work Crew [40 h] | 2,745.43 |  |  |  |  |  |  |  |  | 1.3.3.30 | CONS | CONS | ZONE-3 | ROAD-3 | MECH | SEA-W |

Notes:
- CON-Z3-UT-SW-VC-1850: Expenses: (New Expense Item) 1715.89
- CON-Z3-UT-SW-VC-1860: Expenses: (New Expense Item) 1029.54
- CON-Z3-UT-SW-VC-1890: Expenses: (New Expense Item) 1715.89
- CON-Z3-UT-SW-VC-1870: Expenses: (New Expense Item) 1715.89
- CON-Z3-UT-SW-VC-1880: Expenses: (New Expense Item) 1715.89
- CON-Z3-UT-SW-VC-1910: Expenses: (New Expense Item) 3431.79
- CON-Z3-UT-SW-VC-1900: Expenses: (New Expense Item) 1715.89
- CON-Z3-UT-SW-VC-1920: Expenses: (New Expense Item) 3431.79
- CON-Z3-UT-SW-VC-1930: Expenses: (New Expense Item) 686.36
- CON-Z3-UT-SW-VC-1950: Expenses: (New Expense Item) 1029.54
- CON-Z3-UT-SW-VC-1940: Expenses: (New Expense Item) 6863.57
- CON-Z3-UT-SW-VC-1960: Expenses: (New Expense Item) 686.36
- CON-Z3-UT-SW-VC-1970: Expenses: (New Expense Item) 3431.79
- CON-Z3-UT-SW-VC-1980: Expenses: (New Expense Item) 5147.68
- CON-Z3-UT-SW-VC-1990: Expenses: (New Expense Item) 1715.89
- CON-Z3-UT-SW-VC-2000: Expenses: (New Expense Item) 1029.54
- CON-Z3-UT-SW-VC-2030: Expenses: (New Expense Item) 1715.89
- CON-Z3-UT-SW-VC-2010: Expenses: (New Expense Item) 1715.89
- CON-Z3-UT-SW-VC-2020: Expenses: (New Expense Item) 1715.89
- CON-Z3-UT-SW-VC-2050: Expenses: (New Expense Item) 3431.79
- CON-Z3-UT-SW-VC-2040: Expenses: (New Expense Item) 1715.89
- CON-Z3-UT-SW-VC-2060: Expenses: (New Expense Item) 3431.79
- CON-Z3-UT-SW-VC-2070: Expenses: (New Expense Item) 686.36
- CON-Z3-UT-SW-VC-2090: Expenses: (New Expense Item) 1029.54
- CON-Z3-UT-SW-VC-2080: Expenses: (New Expense Item) 5147.68
- CON-Z3-UT-SW-VC-8360: Expenses: (New Expense Item) 2402.25
- CON-Z3-UT-SW-VC-8370: Expenses: (New Expense Item) 3431.79
- CON-Z3-UT-SW-VC-3000: Expenses: (New Expense Item) 686.36
- CON-Z3-UT-SW-VC-3010: Expenses: (New Expense Item) 1715.89
- CON-Z3-UT-SW-VC-8380: Expenses: (New Expense Item) 2745.43

| ID | WBS | Activity | Duration | Start | Finish | Predecessors | Total float | Free float | Resources | Cost | Activity Wt% | Weight % | Cost Wt | RPI - PHASE | RPI - CONSTRUCTION | RPI - ZONES | RPI - UTILITY NETWORKS | RPI - TYPE OF WORK | RPI_P2 - BOQ ITEMS | RPI_P2 - CONSTRUCTION | RPI_P2 - PHASE | RPI_P2 - ZONES | RPI_P2 - AREAS | RPI_P2 - DISCIPLINE / WORK TYPE | RPI_P2 - UTILITY NETWORK |
| --- | --- | --- | --- | --- | --- | --- | --- | --- | --- | --- | --- | --- | --- | --- | --- | --- | --- | --- | --- | --- | --- | --- | --- | --- | --- |
|  | 15 | **Chamber - VB-NCL-05 at Road 3** |  | 2017-05-27 | 2017-07-03 |  |  |  |  |  |  |  |  |  |  |  |  |  |  |  |  |  |  |  |  |
| CON-Z3-UT-SW-VC-3030 |  | Excavation and Compaction | 1.6d | 2017-05-27 | 2017-05-29 | CON-Z3-UT-SW-VC-1990 FS+5d | 30.8d | 0d | Operator - Excavator [26 h] | 1,715.89 | 0 | 0 | 0.0030836221 | 6 | RPI - CONS | Z2 | PW | MECH | 1.3.3.30 | CONS | CONS | ZONE-3 | ROAD-3 | MECH | SEA-W |
| CON-Z3-UT-SW-VC-3040 |  | Lean concrete | 0.8d | 2017-05-29 | 2017-05-30 | CON-Z3-UT-SW-VC-3030 | 57.2d | 0d | Concrete Mason [52 h]; Driver - Conc. Transit Mixers [26 h]; Operator - Concrete Pump [26 h] | 1,029.54 | 0 | 0 | 0.0003088871 | 6 | RPI - CONS | Z2 | PW | MECH | 1.3.3.30 | CONS | CONS | ZONE-3 | ROAD-3 | MECH | SEA-W |
| CON-Z3-UT-SW-VC-3070 |  | Formwork for Base Slab | 0.8d | 2017-05-30 | 2017-05-30 | CON-Z3-UT-SW-VC-3040 | 57.2d | 0d | Shuttering Carpenter [78 h]; Common Labor / Helper [52 h] | 1,715.89 | 0 | 0 | 0.000308358 | 6 | RPI - CONS | Z2 | PW | MECH | 1.3.3.30 | CONS | CONS | ZONE-3 | ROAD-3 | MECH | SEA-W |
| CON-Z3-UT-SW-VC-3050 |  | Fabrication & installation of Rebar for Base Slab | 4d | 2017-05-31 | 2017-06-04 | CON-Z3-UT-SW-VC-3070 | 57.2d | 0d | Steel Fixer [78 h] | 1,715.89 | 0 | 0 | 0.0015418111 | 6 | RPI - CONS | Z2 | PW | MECH | 1.3.3.30 | CONS | CONS | ZONE-3 | ROAD-3 | MECH | SEA-W |
| CON-Z3-UT-SW-VC-3060 |  | Fabrication & installation of Rebar for Side walls | 4d | 2017-06-05 | 2017-06-08 | CON-Z3-UT-SW-VC-3050 | 57.2d | 0d | Steel Fixer [600 h] | 1,715.89 | 0 | 0 | 0.0030836221 | 6 | RPI - CONS | Z2 | PW | MECH | 1.3.3.30 | CONS | CONS | ZONE-3 | ROAD-3 | MECH | SEA-W |
| CON-Z3-UT-SW-VC-3090 |  | Formwork for side walls | 4d | 2017-06-05 | 2017-06-10 | CON-Z3-UT-SW-VC-3060 SS+0.8d | 57.2d | 0d | Shuttering Carpenter [600 h]; Common Labor / Helper [40 h]; Scaffolder [400 h] | 3,431.79 | 0 | 0 | 0.0015418111 | 6 | RPI - CONS | Z2 | PW | MECH | 1.3.3.30 | CONS | CONS | ZONE-3 | ROAD-3 | MECH | SEA-W |
| CON-Z3-UT-SW-VC-3080 |  | Concrete pouring for base slab | 0.8d | 2017-06-10 | 2017-06-11 | CON-Z3-UT-SW-VC-3090 | 57.2d | 0d | Concrete Mason [78 h]; Common Labor / Helper [8 h]; Finishing Work Crew [80 h]; Driver - Conc. Transit Mixers [26 h]; Operator - Concrete Pump [26 h] | 1,715.89 | 0 | 0 | 0.0015418111 | 6 | RPI - CONS | Z2 | PW | MECH | 1.3.3.30 | CONS | CONS | ZONE-3 | ROAD-3 | MECH | SEA-W |
| CON-Z3-UT-SW-VC-4000 |  | Concrete pouring for Side Wall | 0.8d | 2017-06-11 | 2017-06-12 | CON-Z3-UT-SW-VC-3080 | 57.2d | 0d | Concrete Mason [78 h]; Common Labor / Helper [8 h]; Finishing Work Crew [52 h]; Driver - Conc. Transit Mixers [26 h]; Operator - Concrete Pump [26 h] | 3,431.79 | 0 | 0 | 0.0040086961 | 6 | RPI - CONS | Z2 | PW | MECH | 1.3.3.30 | CONS | CONS | ZONE-3 | ROAD-3 | MECH | SEA-W |
| CON-Z3-UT-SW-VC-4010 |  | Formwork removal and concrete patching | 1.6d | 2017-06-12 | 2017-06-13 | CON-Z3-UT-SW-VC-4000 | 57.2d | 0d | Shuttering Carpenter [16 h]; Scaffolder [16 h]; Finishing Work Crew [16 h] | 686.36 | 0 | 0 | 0.0015418111 | 6 | RPI - CONS | Z2 | PW | MECH | 1.3.3.30 | CONS | CONS | ZONE-3 | ROAD-3 | MECH | SEA-W |
| CON-Z3-UT-SW-VC-4030 |  | Concrete Supports | 0.8d | 2017-06-14 | 2017-06-14 | CON-Z3-UT-SW-VC-4010 | 57.2d | 0d | Shuttering Carpenter [120 h]; Concrete Mason [120 h]; Common Labor / Helper [8 h] | 1,029.54 | 0 | 0 | 0.000616716 | 6 | RPI - CONS | Z2 | PW | MECH | 1.3.3.30 | CONS | CONS | ZONE-3 | ROAD-3 | MECH | SEA-W |
| CON-Z3-UT-SW-VC-4020 |  | Installation of Pipe Connections / Closing of Openings | 3.2d | 2017-06-14 | 2017-06-18 | CON-Z3-UT-SW-VC-4030 | 57.2d | 0d | Shuttering Carpenter [320 h]; Concrete Mason [320 h]; Plumber [480 h]; Common Labor / Helper [32 h] | 5,147.68 | 0 | 0 | 0.0055505071 | 6 | RPI - CONS | Z2 | PW | MECH | 1.3.3.30 | CONS | CONS | ZONE-3 | ROAD-3 | MECH | SEA-W |
| CON-Z3-UT-SW-VC-8390 |  | Installation of Dismantling joints | 2.4d | 2017-06-14 | 2017-06-18 | CON-Z3-UT-SW-VC-4020 SS | 58.8d | 0d | Common Labor / Helper [24 h]; RTR Pipe Crew [31.2 h]; Plumber [24 h] | 2,402.25 |  |  |  |  |  |  |  |  | 1.3.3.30 | CONS | CONS | ZONE-3 | ROAD-3 | MECH | SEA-W |
| CON-Z3-UT-SW-VC-8400 |  | Installation of Valves | 4d | 2017-06-18 | 2017-06-22 | CON-Z3-UT-SW-VC-8390 | 58.8d | 1.6d | Common Labor / Helper [40 h]; RTR Pipe Crew [200 h]; Plumber [400 h] | 3,431.79 |  |  |  |  |  |  |  |  | 1.3.3.30 | CONS | CONS | ZONE-3 | ROAD-3 | MECH | SEA-W |
| CON-Z3-UT-SW-VC-4040 |  | Damp Proof Coating | 0.8d | 2017-06-19 | 2017-06-19 | CON-Z3-UT-SW-VC-4010, CON-Z3-UT-SW-VC-4020 | 57.2d | 0d | Painter [8 h]; Water Proofing Crew [8 h] | 686.36 | 0 | 0 | 0.0015418111 | 6 | RPI - CONS | Z2 | PW | MECH | 1.3.3.30 | CONS | CONS | ZONE-3 | ROAD-3 | MECH | SEA-W |
| CON-Z3-UT-SW-VC-4050 |  | Backfilling & Compaction | 4d | 2017-06-19 | 2017-06-24 | CON-Z3-UT-SW-VC-4040 | 57.2d | 0d | Common Labor / Helper [40 h]; Driver - Dump Truck [52 h]; Operator - Bobcat [52 h]; Operator - Roller-Compactor (2~10 Ton) [52 h]; Driver - Water Tanker [52 h]; Operator - JCB [52 h]; Bobcat [56 h]; Plate Compactor [56 h]; Vibrators [56 h]; Water Tanker [56 h]; JCB [56 h] | 1,715.89 | 0 | 0 | 0.0037003381 | 6 | RPI - CONS | Z2 | PW | MECH | 1.3.3.30 | CONS | CONS | ZONE-3 | ROAD-3 | MECH | SEA-W |
| CON-Z3-UT-SW-VC-8410 |  | Installation of Roof Slab, Manhole Cover, Accessories & Finishes | 4d | 2017-06-24 | 2017-07-03 | CON-Z3-UT-SW-VC-4050, CON-Z3-UT-SW-VC-8380 SS, CON-Z3-UT-SW-VC-8400 | 57.2d | 6.6d | Common Labor / Helper [40 h]; Finishing Work Crew [200 h] | 2,745.43 |  |  |  |  |  |  |  |  | 1.3.3.30 | CONS | CONS | ZONE-3 | ROAD-3 | MECH | SEA-W |
|  | 17 | **Air Release Valve Chamber (AV-5) at Road 3** |  | 2017-06-04 | 2017-07-11 |  |  |  |  |  |  |  |  |  |  |  |  |  |  |  |  |  |  |  |  |
| CON-Z3-UT-SW-VC-4070 |  | Excavation and Compaction | 1.6d | 2017-06-04 | 2017-06-05 | CON-Z3-UT-SW-VC-3030 FS+5d | 30.8d | 0d | Operator - Excavator [16 h]; Excavator [22.4 h] | 1,715.89 | 0 | 0 | 0.0030836221 | 6 | RPI - CONS | Z2 | PW | MECH | 1.3.3.30 | CONS | CONS | ZONE-3 | ROAD-3 | MECH | SEA-W |
| CON-Z3-UT-SW-VC-4080 |  | Lean concrete | 0.8d | 2017-06-06 | 2017-06-06 | CON-Z3-UT-SW-VC-4070 | 50.6d | 0d | Concrete Mason [80 h]; Driver - Conc. Transit Mixers [26 h]; Operator - Concrete Pump [26 h] | 1,029.54 | 0 | 0 | 0.0003088871 | 6 | RPI - CONS | Z2 | PW | MECH | 1.3.3.30 | CONS | CONS | ZONE-3 | ROAD-3 | MECH | SEA-W |
| CON-Z3-UT-SW-VC-5010 |  | Formwork for Base Slab | 0.8d | 2017-06-06 | 2017-06-07 | CON-Z3-UT-SW-VC-4080 | 50.6d | 0d | Shuttering Carpenter [78 h]; Common Labor / Helper [8 h] | 1,715.89 | 0 | 0 | 0.000308358 | 6 | RPI - CONS | Z2 | PW | MECH | 1.3.3.30 | CONS | CONS | ZONE-3 | ROAD-3 | MECH | SEA-W |
| CON-Z3-UT-SW-VC-4090 |  | Fabrication & installation of Rebar for Base Slab | 4d | 2017-06-07 | 2017-06-12 | CON-Z3-UT-SW-VC-5010 | 50.6d | 0d | Steel Fixer [600 h] | 1,715.89 | 0 | 0 | 0.0015418111 | 6 | RPI - CONS | Z2 | PW | MECH | 1.3.3.30 | CONS | CONS | ZONE-3 | ROAD-3 | MECH | SEA-W |
| CON-Z3-UT-SW-VC-5000 |  | Fabrication & installation of Rebar for Side walls | 4d | 2017-06-12 | 2017-06-17 | CON-Z3-UT-SW-VC-4090 | 50.6d | 0d | Steel Fixer [600 h] | 1,715.89 | 0 | 0 | 0.0030836221 | 6 | RPI - CONS | Z2 | PW | MECH | 1.3.3.30 | CONS | CONS | ZONE-3 | ROAD-3 | MECH | SEA-W |
| CON-Z3-UT-SW-VC-5030 |  | Formwork for side walls | 4d | 2017-06-13 | 2017-06-18 | CON-Z3-UT-SW-VC-5000 SS+0.8d | 50.6d | 0d | Shuttering Carpenter [40 h]; Common Labor / Helper [40 h]; Scaffolder [40 h] | 3,431.79 | 0 | 0 | 0.0015418111 | 6 | RPI - CONS | Z2 | PW | MECH | 1.3.3.30 | CONS | CONS | ZONE-3 | ROAD-3 | MECH | SEA-W |
| CON-Z3-UT-SW-VC-5020 |  | Concrete pouring for base slab | 0.8d | 2017-06-18 | 2017-06-19 | CON-Z3-UT-SW-VC-5030 | 50.6d | 0d | Concrete Mason [78 h]; Common Labor / Helper [8 h]; Finishing Work Crew [52 h]; Driver - Conc. Transit Mixers [26 h]; Operator - Concrete Pump [26 h] | 1,715.89 | 0 | 0 | 0.0015418111 | 6 | RPI - CONS | Z2 | PW | MECH | 1.3.3.30 | CONS | CONS | ZONE-3 | ROAD-3 | MECH | SEA-W |
| CON-Z3-UT-SW-VC-5040 |  | Concrete pouring for Side Wall | 0.8d | 2017-06-19 | 2017-06-19 | CON-Z3-UT-SW-VC-5020 | 50.6d | 0d | Common Labor / Helper [8 h]; Finishing Work Crew [52 h]; Driver - Conc. Transit Mixers [26 h]; Operator - Concrete Pump [26 h]; Concrete Mason [8 h] | 3,431.79 | 0 | 0 | 0.0040086961 | 6 | RPI - CONS | Z2 | PW | MECH | 1.3.3.30 | CONS | CONS | ZONE-3 | ROAD-3 | MECH | SEA-W |
| CON-Z3-UT-SW-VC-5050 |  | Formwork removal and concrete patching | 1.6d | 2017-06-20 | 2017-06-21 | CON-Z3-UT-SW-VC-5040 | 50.6d | 0d | Shuttering Carpenter [160 h]; Scaffolder [80 h]; Finishing Work Crew [80 h] | 686.36 | 0 | 0 | 0.0015418111 | 6 | RPI - CONS | Z2 | PW | MECH | 1.3.3.30 | CONS | CONS | ZONE-3 | ROAD-3 | MECH | SEA-W |
| CON-Z3-UT-SW-VC-5070 |  | Concrete Supports | 0.8d | 2017-06-21 | 2017-06-22 | CON-Z3-UT-SW-VC-5050 | 50.6d | 0d | Shuttering Carpenter [8 h]; Concrete Mason [8 h]; Common Labor / Helper [8 h] | 1,029.54 | 0 | 0 | 0.000616716 | 6 | RPI - CONS | Z2 | PW | MECH | 1.3.3.30 | CONS | CONS | ZONE-3 | ROAD-3 | MECH | SEA-W |
| CON-Z3-UT-SW-VC-5060 |  | Installation of Pipe Connections / Closing of Openings | 3.2d | 2017-06-22 | 2017-07-01 | CON-Z3-UT-SW-VC-5070 | 50.6d | 0d | Shuttering Carpenter [32 h]; Concrete Mason [32 h]; Plumber [32 h]; Common Labor / Helper [32 h] | 5,147.68 | 0 | 0 | 0.0055505071 | 6 | RPI - CONS | Z2 | PW | MECH | 1.3.3.30 | CONS | CONS | ZONE-3 | ROAD-3 | MECH | SEA-W |
| CON-Z3-UT-SW-VC-8120 |  | Installation of Gate valves | 3d | 2017-06-22 | 2017-07-01 | CON-Z3-UT-SW-VC-5060 SS | 53.2d | 0d | Common Labor / Helper [240 h]; RTR Pipe Crew [90 h]; Plumber [150 h] | 2,402.25 | 0 | 0 | 0.002466885 | 6 | RPI - CONS | Z2 | PW | MECH | 1.3.3.30 | CONS | CONS | ZONE-3 | ROAD-3 | MECH | SEA-W |
| CON-Z3-UT-SW-VC-8130 |  | Installation of Air Release Valves | 2.4d | 2017-07-01 | 2017-07-03 | CON-Z3-UT-SW-VC-8120 | 53.2d | 2.6d | Common Labor / Helper [24 h]; RTR Pipe Crew [24 h] | 3,431.79 |  |  |  |  |  |  |  |  | 1.3.3.30 | CONS | CONS | ZONE-3 | ROAD-3 | MECH | SEA-W |
| CON-Z3-UT-SW-VC-5080 |  | Damp Proof Coating | 0.8d | 2017-07-01 | 2017-07-02 | CON-Z3-UT-SW-VC-5050, CON-Z3-UT-SW-VC-5060 | 50.6d | 0d | Painter [8 h]; Water Proofing Crew [8 h] | 686.36 | 0 | 0 | 0.0015418111 | 6 | RPI - CONS | Z2 | PW | MECH | 1.3.3.30 | CONS | CONS | ZONE-3 | ROAD-3 | MECH | SEA-W |
| CON-Z3-UT-SW-VC-5090 |  | Backfilling & Compaction | 4d | 2017-07-02 | 2017-07-06 | CON-Z3-UT-SW-VC-5080 | 50.6d | 0d | Common Labor / Helper [40 h]; Driver - Dump Truck [52 h]; Operator - Bobcat [52 h]; Operator - Roller-Compactor (2~10 Ton) [52 h]; Driver - Water Tanker [52 h]; Operator - JCB [52 h]; Bobcat [56 h]; Plate Compactor [56 h]; Vibrators [56 h]; Water Tanker [56 h]; JCB [56 h] | 1,715.89 | 0 | 0 | 0.0037003381 | 6 | RPI - CONS | Z2 | PW | MECH | 1.3.3.30 | CONS | CONS | ZONE-3 | ROAD-3 | MECH | SEA-W |
| CON-Z3-UT-SW-VC-8140 |  | Installation of Roof Slab, Manhole Cover, Accessories & Finishes | 4d | 2017-07-06 | 2017-07-11 | CON-Z3-UT-SW-VC-5090, CON-Z3-UT-SW-VC-8410 SS, CON-Z3-UT-SW-VC-8130 | 50.6d | 6.6d | Common Labor / Helper [40 h]; Finishing Work Crew [40 h] | 2,745.43 |  |  |  |  |  |  |  |  | 1.3.3.30 | CONS | CONS | ZONE-3 | ROAD-3 | MECH | SEA-W |

Notes:
- CON-Z3-UT-SW-VC-3030: Expenses: (New Expense Item) 1715.89
- CON-Z3-UT-SW-VC-3040: Expenses: (New Expense Item) 1029.54
- CON-Z3-UT-SW-VC-3070: Expenses: (New Expense Item) 1715.89
- CON-Z3-UT-SW-VC-3050: Expenses: (New Expense Item) 1715.89
- CON-Z3-UT-SW-VC-3060: Expenses: (New Expense Item) 1715.89
- CON-Z3-UT-SW-VC-3090: Expenses: (New Expense Item) 3431.79
- CON-Z3-UT-SW-VC-3080: Expenses: (New Expense Item) 1715.89
- CON-Z3-UT-SW-VC-4000: Expenses: (New Expense Item) 3431.79
- CON-Z3-UT-SW-VC-4010: Expenses: (New Expense Item) 686.36
- CON-Z3-UT-SW-VC-4030: Expenses: (New Expense Item) 1029.54
- CON-Z3-UT-SW-VC-4020: Expenses: (New Expense Item) 5147.68
- CON-Z3-UT-SW-VC-8390: Expenses: (New Expense Item) 2402.25
- CON-Z3-UT-SW-VC-8400: Expenses: (New Expense Item) 3431.79
- CON-Z3-UT-SW-VC-4040: Expenses: (New Expense Item) 686.36
- CON-Z3-UT-SW-VC-4050: Expenses: (New Expense Item) 1715.89
- CON-Z3-UT-SW-VC-8410: Expenses: (New Expense Item) 2745.43
- CON-Z3-UT-SW-VC-4070: Expenses: (New Expense Item) 1715.89
- CON-Z3-UT-SW-VC-4080: Expenses: (New Expense Item) 1029.54
- CON-Z3-UT-SW-VC-5010: Expenses: (New Expense Item) 1715.89
- CON-Z3-UT-SW-VC-4090: Expenses: (New Expense Item) 1715.89
- CON-Z3-UT-SW-VC-5000: Expenses: (New Expense Item) 1715.89
- CON-Z3-UT-SW-VC-5030: Expenses: (New Expense Item) 3431.79
- CON-Z3-UT-SW-VC-5020: Expenses: (New Expense Item) 1715.89
- CON-Z3-UT-SW-VC-5040: Expenses: (New Expense Item) 3431.79
- CON-Z3-UT-SW-VC-5050: Expenses: (New Expense Item) 686.36
- CON-Z3-UT-SW-VC-5070: Expenses: (New Expense Item) 1029.54
- CON-Z3-UT-SW-VC-5060: Expenses: (New Expense Item) 5147.68
- CON-Z3-UT-SW-VC-8120: Expenses: (New Expense Item) 2402.25
- CON-Z3-UT-SW-VC-8130: Expenses: (New Expense Item) 3431.79
- CON-Z3-UT-SW-VC-5080: Expenses: (New Expense Item) 686.36
- CON-Z3-UT-SW-VC-5090: Expenses: (New Expense Item) 1715.89
- CON-Z3-UT-SW-VC-8140: Expenses: (New Expense Item) 2745.43

| ID | WBS | Activity | Duration | Start | Finish | Predecessors | Total float | Free float | Resources | Cost | Activity Wt% | Weight % | Cost Wt | RPI - PHASE | RPI - CONSTRUCTION | RPI - ZONES | RPI - UTILITY NETWORKS | RPI - TYPE OF WORK | RPI_P2 - BOQ ITEMS | RPI_P2 - CONSTRUCTION | RPI_P2 - PHASE | RPI_P2 - ZONES | RPI_P2 - AREAS | RPI_P2 - DISCIPLINE / WORK TYPE | RPI_P2 - UTILITY NETWORK |
| --- | --- | --- | --- | --- | --- | --- | --- | --- | --- | --- | --- | --- | --- | --- | --- | --- | --- | --- | --- | --- | --- | --- | --- | --- | --- |
|  | 18 | **Air Release Valve Chamber (AV-4) at Road 5** |  | 2017-06-12 | 2017-07-18 |  |  |  |  |  |  |  |  |  |  |  |  |  |  |  |  |  |  |  |  |
| CON-Z3-UT-SW-VC-6010 |  | Excavation and Compaction | 1.6d | 2017-06-12 | 2017-06-13 | CON-Z3-UT-SW-VC-4070 FS+5d | 30.8d | 0d | Operator - Excavator [26 h]; Excavator [22.4 h] | 1,715.89 | 0 | 0 | 0.0030836221 | 6 | RPI - CONS | Z2 | PW | MECH | 1.3.3.30 | CONS | CONS | ZONE-3 | ROAD-5 | MECH | SEA-W |
| CON-Z3-UT-SW-VC-6020 |  | Lean concrete | 0.8d | 2017-06-13 | 2017-06-14 | CON-Z3-UT-SW-VC-6010 | 44d | 0d | Concrete Mason [8 h]; Driver - Conc. Transit Mixers [26 h]; Operator - Concrete Pump [26 h] | 1,029.54 | 0 | 0 | 0.0003088871 | 6 | RPI - CONS | Z2 | PW | MECH | 1.3.3.30 | CONS | CONS | ZONE-3 | ROAD-5 | MECH | SEA-W |
| CON-Z3-UT-SW-VC-6050 |  | Formwork for Base Slab | 0.8d | 2017-06-14 | 2017-06-15 | CON-Z3-UT-SW-VC-6020 | 44d | 0d | Shuttering Carpenter [8 h]; Common Labor / Helper [8 h] | 1,715.89 | 0 | 0 | 0.000308358 | 6 | RPI - CONS | Z2 | PW | MECH | 1.3.3.30 | CONS | CONS | ZONE-3 | ROAD-5 | MECH | SEA-W |
| CON-Z3-UT-SW-VC-6030 |  | Fabrication & installation of Rebar for Base Slab | 4d | 2017-06-15 | 2017-06-20 | CON-Z3-UT-SW-VC-6050 | 44d | 0d | Steel Fixer [80 h] | 1,715.89 | 0 | 0 | 0.0015418111 | 6 | RPI - CONS | Z2 | PW | MECH | 1.3.3.30 | CONS | CONS | ZONE-3 | ROAD-5 | MECH | SEA-W |
| CON-Z3-UT-SW-VC-6040 |  | Fabrication & installation of Rebar for Side walls | 4d | 2017-06-20 | 2017-06-25 | CON-Z3-UT-SW-VC-6030 | 44d | 0d | Steel Fixer [80 h] | 1,715.89 | 0 | 0 | 0.0030836221 | 6 | RPI - CONS | Z2 | PW | MECH | 1.3.3.30 | CONS | CONS | ZONE-3 | ROAD-5 | MECH | SEA-W |
| CON-Z3-UT-SW-VC-6070 |  | Formwork for side walls | 4d | 2017-06-21 | 2017-06-25 | CON-Z3-UT-SW-VC-6040 SS+0.8d | 44d | 0d | Shuttering Carpenter [600 h]; Common Labor / Helper [200 h]; Scaffolder [400 h] | 3,431.79 | 0 | 0 | 0.0015418111 | 6 | RPI - CONS | Z2 | PW | MECH | 1.3.3.30 | CONS | CONS | ZONE-3 | ROAD-5 | MECH | SEA-W |
| CON-Z3-UT-SW-VC-6060 |  | Concrete pouring for base slab | 0.8d | 2017-07-01 | 2017-07-01 | CON-Z3-UT-SW-VC-6070 | 44d | 0d | Concrete Mason [8 h]; Common Labor / Helper [8 h]; Finishing Work Crew [8 h]; Driver - Conc. Transit Mixers [10.4 h]; Operator - Concrete Pump [10.4 h] | 1,715.89 | 0 | 0 | 0.0015418111 | 6 | RPI - CONS | Z2 | PW | MECH | 1.3.3.30 | CONS | CONS | ZONE-3 | ROAD-5 | MECH | SEA-W |
| CON-Z3-UT-SW-VC-6080 |  | Concrete pouring for Side Wall | 0.8d | 2017-07-01 | 2017-07-02 | CON-Z3-UT-SW-VC-6060 | 44d | 0d | Concrete Mason [8 h]; Common Labor / Helper [8 h]; Finishing Work Crew [8 h]; Driver - Conc. Transit Mixers [8 h]; Operator - Concrete Pump [8 h] | 3,431.79 | 0 | 0 | 0.0040086961 | 6 | RPI - CONS | Z2 | PW | MECH | 1.3.3.30 | CONS | CONS | ZONE-3 | ROAD-5 | MECH | SEA-W |
| CON-Z3-UT-SW-VC-6090 |  | Formwork removal and concrete patching | 1.6d | 2017-07-02 | 2017-07-04 | CON-Z3-UT-SW-VC-6080 | 44d | 0d | Shuttering Carpenter [16 h]; Scaffolder [16 h]; Finishing Work Crew [16 h] | 686.36 | 0 | 0 | 0.0015418111 | 6 | RPI - CONS | Z2 | PW | MECH | 1.3.3.30 | CONS | CONS | ZONE-3 | ROAD-5 | MECH | SEA-W |
| CON-Z3-UT-SW-VC-7010 |  | Concrete Supports | 0.8d | 2017-07-04 | 2017-07-04 | CON-Z3-UT-SW-VC-6090 | 44d | 0d | Shuttering Carpenter [8 h]; Concrete Mason [8 h]; Common Labor / Helper [8 h] | 1,029.54 | 0 | 0 | 0.000616716 | 6 | RPI - CONS | Z2 | PW | MECH | 1.3.3.30 | CONS | CONS | ZONE-3 | ROAD-5 | MECH | SEA-W |
| CON-Z3-UT-SW-VC-7000 |  | Installation of Pipe Connections / Closing of Openings | 3.2d | 2017-07-05 | 2017-07-09 | CON-Z3-UT-SW-VC-7010 | 44d | 0d | Shuttering Carpenter [32 h]; Concrete Mason [32 h]; Plumber [32 h]; Common Labor / Helper [32 h] | 5,147.68 | 0 | 0 | 0.0055505071 | 6 | RPI - CONS | Z2 | PW | MECH | 1.3.3.30 | CONS | CONS | ZONE-3 | ROAD-5 | MECH | SEA-W |
| CON-Z3-UT-SW-VC-8150 |  | Installation of Gate valves | 3d | 2017-07-05 | 2017-07-08 | CON-Z3-UT-SW-VC-7000 SS | 46.6d | 0d | Common Labor / Helper [30 h]; RTR Pipe Crew [39 h] | 2,402.25 | 0 | 0 | 0.002466885 | 6 | RPI - CONS | Z2 | PW | MECH | 1.3.3.30 | CONS | CONS | ZONE-3 | ROAD-5 | MECH | SEA-W |
| CON-Z3-UT-SW-VC-8160 |  | Installation of Air Release Valves | 2.4d | 2017-07-09 | 2017-07-11 | CON-Z3-UT-SW-VC-8150 | 46.6d | 2.6d | Common Labor / Helper [24 h]; RTR Pipe Crew [31.2 h] | 3,431.79 |  |  |  |  |  |  |  |  | 1.3.3.30 | CONS | CONS | ZONE-3 | ROAD-5 | MECH | SEA-W |
| CON-Z3-UT-SW-VC-7020 |  | Damp Proof Coating | 0.8d | 2017-07-09 | 2017-07-09 | CON-Z3-UT-SW-VC-6090, CON-Z3-UT-SW-VC-7000 | 44d | 0d | Painter [8 h]; Water Proofing Crew [8 h] | 686.36 | 0 | 0 | 0.0015418111 | 6 | RPI - CONS | Z2 | PW | MECH | 1.3.3.30 | CONS | CONS | ZONE-3 | ROAD-5 | MECH | SEA-W |
| CON-Z3-UT-SW-VC-7030 |  | Backfilling & Compaction | 4d | 2017-07-10 | 2017-07-13 | CON-Z3-UT-SW-VC-7020 | 44d | 0d | Common Labor / Helper [52 h]; Driver - Dump Truck [26 h]; Operator - Bobcat [26 h]; Operator - Roller-Compactor (2~10 Ton) [26 h]; Driver - Water Tanker [26 h]; Operator - JCB [26 h]; Bobcat [28 h]; Plate Compactor [28 h]; Vibrators [28 h]; Water Tanker [28 h]; JCB [28 h] | 1,715.89 | 0 | 0 | 0.0037003381 | 6 | RPI - CONS | Z2 | PW | MECH | 1.3.3.30 | CONS | CONS | ZONE-3 | ROAD-5 | MECH | SEA-W |
| CON-Z3-UT-SW-VC-8170 |  | Installation of Roof Slab, Manhole Cover, Accessories & Finishes | 4d | 2017-07-15 | 2017-07-18 | CON-Z3-UT-SW-VC-8140 SS, CON-Z3-UT-SW-VC-8160, CON-Z3-UT-SW-VC-7030 | 44d | 6.6d | Common Labor / Helper [40 h]; Finishing Work Crew [52 h] | 2,745.43 |  |  |  |  |  |  |  |  | 1.3.3.30 | CONS | CONS | ZONE-3 | ROAD-5 | MECH | SEA-W |
|  | 19 | **Isolation Valve Chamber (ISV-4) at Junction of Road 5** |  | 2017-06-19 | 2017-07-26 |  |  |  |  |  |  |  |  |  |  |  |  |  |  |  |  |  |  |  |  |
| CON-Z3-UT-SW-VC-7050 |  | Excavation and Compaction | 1.6d | 2017-06-19 | 2017-06-21 | CON-Z3-UT-SW-VC-6010 FS+5d | 30.8d | 0d | Operator - Excavator [26 h]; Excavator [22.4 h] | 1,715.89 | 0 | 0 | 0.0030836221 | 6 | RPI - CONS | Z2 | PW | MECH | 1.3.3.30 | CONS | CONS | ZONE-3 | ROAD-5 | MECH | SEA-W |
| CON-Z3-UT-SW-VC-7060 |  | Lean concrete | 0.8d | 2017-06-21 | 2017-06-21 | CON-Z3-UT-SW-VC-7050 | 37.4d | 0d | Concrete Mason [80 h]; Driver - Conc. Transit Mixers [26 h]; Operator - Concrete Pump [26 h] | 1,029.54 | 0 | 0 | 0.0003088871 | 6 | RPI - CONS | Z2 | PW | MECH | 1.3.3.30 | CONS | CONS | ZONE-3 | ROAD-5 | MECH | SEA-W |
| CON-Z3-UT-SW-VC-7090 |  | Formwork for Base Slab | 0.8d | 2017-06-22 | 2017-06-22 | CON-Z3-UT-SW-VC-7060 | 37.4d | 0d | Shuttering Carpenter [120 h]; Common Labor / Helper [80 h] | 1,715.89 | 0 | 0 | 0.000308358 | 6 | RPI - CONS | Z2 | PW | MECH | 1.3.3.30 | CONS | CONS | ZONE-3 | ROAD-5 | MECH | SEA-W |
| CON-Z3-UT-SW-VC-7070 |  | Fabrication & installation of Rebar for Base Slab | 4d | 2017-06-22 | 2017-07-02 | CON-Z3-UT-SW-VC-7090 | 37.4d | 0d | Steel Fixer [400 h] | 1,715.89 | 0 | 0 | 0.0015418111 | 6 | RPI - CONS | Z2 | PW | MECH | 1.3.3.30 | CONS | CONS | ZONE-3 | ROAD-5 | MECH | SEA-W |
| CON-Z3-UT-SW-VC-7080 |  | Fabrication & installation of Rebar for Side walls | 4d | 2017-07-02 | 2017-07-06 | CON-Z3-UT-SW-VC-7070 | 37.4d | 0d | Steel Fixer [40 h] | 1,715.89 | 0 | 0 | 0.0030836221 | 6 | RPI - CONS | Z2 | PW | MECH | 1.3.3.30 | CONS | CONS | ZONE-3 | ROAD-5 | MECH | SEA-W |
| CON-Z3-UT-SW-VC-8010 |  | Formwork for side walls | 4d | 2017-07-03 | 2017-07-08 | CON-Z3-UT-SW-VC-7080 SS+0.8d | 37.4d | 0d | Shuttering Carpenter [40 h]; Common Labor / Helper [40 h]; Scaffolder [40 h] | 3,431.79 | 0 | 0 | 0.0015418111 | 6 | RPI - CONS | Z2 | PW | MECH | 1.3.3.30 | CONS | CONS | ZONE-3 | ROAD-5 | MECH | SEA-W |
| CON-Z3-UT-SW-VC-8000 |  | Concrete pouring for base slab | 0.8d | 2017-07-08 | 2017-07-09 | CON-Z3-UT-SW-VC-8010 | 37.4d | 0d | Concrete Mason [78 h]; Common Labor / Helper [8 h]; Finishing Work Crew [52 h]; Driver - Conc. Transit Mixers [10.4 h]; Operator - Concrete Pump [10.4 h] | 1,715.89 | 0 | 0 | 0.0015418111 | 6 | RPI - CONS | Z2 | PW | MECH | 1.3.3.30 | CONS | CONS | ZONE-3 | ROAD-5 | MECH | SEA-W |
| CON-Z3-UT-SW-VC-8020 |  | Concrete pouring for Side Wall | 0.8d | 2017-07-09 | 2017-07-10 | CON-Z3-UT-SW-VC-8000 | 37.4d | 0d | Concrete Mason [78 h]; Common Labor / Helper [8 h]; Finishing Work Crew [52 h]; Driver - Conc. Transit Mixers [10.4 h]; Operator - Concrete Pump [10.4 h] | 3,431.79 | 0 | 0 | 0.0040086961 | 6 | RPI - CONS | Z2 | PW | MECH | 1.3.3.30 | CONS | CONS | ZONE-3 | ROAD-5 | MECH | SEA-W |
| CON-Z3-UT-SW-VC-8030 |  | Formwork removal and concrete patching | 1.6d | 2017-07-10 | 2017-07-11 | CON-Z3-UT-SW-VC-8020 | 37.4d | 0d | Shuttering Carpenter [16 h]; Scaffolder [16 h]; Finishing Work Crew [16 h] | 686.36 | 0 | 0 | 0.0015418111 | 6 | RPI - CONS | Z2 | PW | MECH | 1.3.3.30 | CONS | CONS | ZONE-3 | ROAD-5 | MECH | SEA-W |
| CON-Z3-UT-SW-VC-8050 |  | Concrete Supports | 0.8d | 2017-07-11 | 2017-07-12 | CON-Z3-UT-SW-VC-8030 | 37.4d | 0d | Shuttering Carpenter [26 h]; Concrete Mason [26 h]; Common Labor / Helper [8 h] | 1,029.54 | 0 | 0 | 0.000616716 | 6 | RPI - CONS | Z2 | PW | MECH | 1.3.3.30 | CONS | CONS | ZONE-3 | ROAD-5 | MECH | SEA-W |
| CON-Z3-UT-SW-VC-8040 |  | Installation of Pipe Connections / Closing of Openings | 3.2d | 2017-07-12 | 2017-07-16 | CON-Z3-UT-SW-VC-8050 | 37.4d | 0d | Shuttering Carpenter [32 h]; Concrete Mason [249.6 h]; Plumber [166.4 h]; Common Labor / Helper [32 h] | 5,147.68 | 0 | 0 | 0.0055505071 | 6 | RPI - CONS | Z2 | PW | MECH | 1.3.3.30 | CONS | CONS | ZONE-3 | ROAD-5 | MECH | SEA-W |
| CON-Z3-UT-SW-VC-8450 |  | Installation of Dismantling joints | 2.4d | 2017-07-12 | 2017-07-15 | CON-Z3-UT-SW-VC-8040 SS | 39d | 0d | Common Labor / Helper [187.2 h]; RTR Pipe Crew [62.4 h] | 2,402.25 |  |  |  |  |  |  |  |  | 1.3.3.30 | CONS | CONS | ZONE-3 | ROAD-5 | MECH | SEA-W |
| CON-Z3-UT-SW-VC-8460 |  | Installation of Valves | 4d | 2017-07-16 | 2017-07-19 | CON-Z3-UT-SW-VC-8450 | 39d | 1.6d | Common Labor / Helper [260 h]; RTR Pipe Crew [104 h] | 3,431.79 |  |  |  |  |  |  |  |  | 1.3.3.30 | CONS | CONS | ZONE-3 | ROAD-5 | MECH | SEA-W |
| CON-Z3-UT-SW-VC-8060 |  | Damp Proof Coating | 0.8d | 2017-07-16 | 2017-07-17 | CON-Z3-UT-SW-VC-8040, CON-Z3-UT-SW-VC-8030 | 37.4d | 0d | Painter [8 h]; Water Proofing Crew [8 h] | 686.36 | 0 | 0 | 0.0015418111 | 6 | RPI - CONS | Z2 | PW | MECH | 1.3.3.30 | CONS | CONS | ZONE-3 | ROAD-5 | MECH | SEA-W |
| CON-Z3-UT-SW-VC-8070 |  | Backfilling & Compaction | 4d | 2017-07-17 | 2017-07-22 | CON-Z3-UT-SW-VC-8060 | 37.4d | 0d | Common Labor / Helper [260 h]; Driver - Dump Truck [52 h]; Operator - Bobcat [52 h]; Operator - Roller-Compactor (2~10 Ton) [52 h]; Driver - Water Tanker [52 h]; Operator - JCB [52 h]; Bobcat [56 h]; Plate Compactor [56 h]; Vibrators [56 h]; Water Tanker [56 h]; JCB [56 h] | 1,715.89 | 0 | 0 | 0.0037003381 | 6 | RPI - CONS | Z2 | PW | MECH | 1.3.3.30 | CONS | CONS | ZONE-3 | ROAD-5 | MECH | SEA-W |
| CON-Z3-UT-SW-VC-8470 |  | Installation of Roof Slab, Manhole Cover, Accessories & Finishes | 4d | 2017-07-22 | 2017-07-26 | CON-Z3-UT-SW-VC-8170 SS, CON-Z3-UT-SW-VC-8460, CON-Z3-UT-SW-VC-8070 | 37.4d | 6.6d | Common Labor / Helper [312 h]; Finishing Work Crew [104 h] | 2,745.43 |  |  |  |  |  |  |  |  | 1.3.3.30 | CONS | CONS | ZONE-3 | ROAD-5 | MECH | SEA-W |

Notes:
- CON-Z3-UT-SW-VC-6010: Expenses: (New Expense Item) 1715.89
- CON-Z3-UT-SW-VC-6020: Expenses: (New Expense Item) 1029.54
- CON-Z3-UT-SW-VC-6050: Expenses: (New Expense Item) 1715.89
- CON-Z3-UT-SW-VC-6030: Expenses: (New Expense Item) 1715.89
- CON-Z3-UT-SW-VC-6040: Expenses: (New Expense Item) 1715.89
- CON-Z3-UT-SW-VC-6070: Expenses: (New Expense Item) 3431.79
- CON-Z3-UT-SW-VC-6060: Expenses: (New Expense Item) 1715.89
- CON-Z3-UT-SW-VC-6080: Expenses: (New Expense Item) 3431.79
- CON-Z3-UT-SW-VC-6090: Expenses: (New Expense Item) 686.36
- CON-Z3-UT-SW-VC-7010: Expenses: (New Expense Item) 1029.54
- CON-Z3-UT-SW-VC-7000: Expenses: (New Expense Item) 5147.68
- CON-Z3-UT-SW-VC-8150: Expenses: (New Expense Item) 2402.25
- CON-Z3-UT-SW-VC-8160: Expenses: (New Expense Item) 3431.79
- CON-Z3-UT-SW-VC-7020: Expenses: (New Expense Item) 686.36
- CON-Z3-UT-SW-VC-7030: Expenses: (New Expense Item) 1715.89
- CON-Z3-UT-SW-VC-8170: Expenses: (New Expense Item) 2745.43
- CON-Z3-UT-SW-VC-7050: Expenses: (New Expense Item) 1715.89
- CON-Z3-UT-SW-VC-7060: Expenses: (New Expense Item) 1029.54
- CON-Z3-UT-SW-VC-7090: Expenses: (New Expense Item) 1715.89
- CON-Z3-UT-SW-VC-7070: Expenses: (New Expense Item) 1715.89
- CON-Z3-UT-SW-VC-7080: Expenses: (New Expense Item) 1715.89
- CON-Z3-UT-SW-VC-8010: Expenses: (New Expense Item) 3431.79
- CON-Z3-UT-SW-VC-8000: Expenses: (New Expense Item) 1715.89
- CON-Z3-UT-SW-VC-8020: Expenses: (New Expense Item) 3431.79
- CON-Z3-UT-SW-VC-8030: Expenses: (New Expense Item) 686.36
- CON-Z3-UT-SW-VC-8050: Expenses: (New Expense Item) 1029.54
- CON-Z3-UT-SW-VC-8040: Expenses: (New Expense Item) 5147.68
- CON-Z3-UT-SW-VC-8450: Expenses: (New Expense Item) 2402.25
- CON-Z3-UT-SW-VC-8460: Expenses: (New Expense Item) 3431.79
- CON-Z3-UT-SW-VC-8060: Expenses: (New Expense Item) 686.36
- CON-Z3-UT-SW-VC-8070: Expenses: (New Expense Item) 1715.89
- CON-Z3-UT-SW-VC-8470: Expenses: (New Expense Item) 2745.43

| ID | WBS | Activity | Duration | Start | Finish | Predecessors | Total float | Free float | Resources | Cost | Activity Wt% | Weight % | Cost Wt | RPI - PHASE | RPI - CONSTRUCTION | RPI - ZONES | RPI - UTILITY NETWORKS | RPI - TYPE OF WORK | RPI_P2 - BOQ ITEMS | RPI_P2 - CONSTRUCTION | RPI_P2 - PHASE | RPI_P2 - ZONES | RPI_P2 - AREAS | RPI_P2 - DISCIPLINE / WORK TYPE | RPI_P2 - UTILITY NETWORK |
| --- | --- | --- | --- | --- | --- | --- | --- | --- | --- | --- | --- | --- | --- | --- | --- | --- | --- | --- | --- | --- | --- | --- | --- | --- | --- |
|  | 25 | **Chamber - VB-NCL-09 at Road 2** |  | 2017-07-02 | 2017-08-03 |  |  |  |  |  |  |  |  |  |  |  |  |  |  |  |  |  |  |  |  |
| CON-Z3-UT-SW-NCL9-10 |  | Excavation and Compaction | 1.6d | 2017-07-02 | 2017-07-03 | CON-Z3-UT-SW-VC-7050 FS+5d | 30.8d | 0d | Operator - Excavator [20.8 h]; Excavator [22.4 h] | 1,715.89 | 0 | 0 | 0.0030836221 | 6 | RPI - CONS | Z2 | PW | MECH | 1.3.3.30 | CONS | CONS | ZONE-3 | ROAD-2 | MECH | SEA-W |
| CON-Z3-UT-SW-NCL9-20 |  | Lean concrete | 0.8d | 2017-07-03 | 2017-07-04 | CON-Z3-UT-SW-NCL9-10 | 30.8d | 0d | Concrete Mason [52 h]; Driver - Conc. Transit Mixers [26 h]; Operator - Concrete Pump [26 h] | 1,029.54 | 0 | 0 | 0.0003088871 | 6 | RPI - CONS | Z2 | PW | MECH | 1.3.3.30 | CONS | CONS | ZONE-3 | ROAD-2 | MECH | SEA-W |
| CON-Z3-UT-SW-NCL9-50 |  | Formwork for Base Slab | 0.8d | 2017-07-04 | 2017-07-05 | CON-Z3-UT-SW-NCL9-20 | 30.8d | 0d | Shuttering Carpenter [78 h]; Common Labor / Helper [52 h] | 1,715.89 | 0 | 0 | 0.000308358 | 6 | RPI - CONS | Z2 | PW | MECH | 1.3.3.30 | CONS | CONS | ZONE-3 | ROAD-2 | MECH | SEA-W |
| CON-Z3-UT-SW-NCL9-30 |  | Fabrication & installation of Rebar for Base Slab | 4d | 2017-07-05 | 2017-07-10 | CON-Z3-UT-SW-NCL9-50 | 30.8d | 0d | Steel Fixer [400 h] | 1,715.89 | 0 | 0 | 0.0015418111 | 6 | RPI - CONS | Z2 | PW | MECH | 1.3.3.30 | CONS | CONS | ZONE-3 | ROAD-2 | MECH | SEA-W |
| CON-Z3-UT-SW-NCL9-40 |  | Fabrication & installation of Rebar for Side walls | 4d | 2017-07-10 | 2017-07-15 | CON-Z3-UT-SW-NCL9-30 | 30.8d | 0d | Steel Fixer [416 h] | 1,715.89 | 0 | 0 | 0.0030836221 | 6 | RPI - CONS | Z2 | PW | MECH | 1.3.3.30 | CONS | CONS | ZONE-3 | ROAD-2 | MECH | SEA-W |
| CON-Z3-UT-SW-NCL9-70 |  | Formwork for side walls | 4d | 2017-07-11 | 2017-07-16 | CON-Z3-UT-SW-NCL9-40 SS+0.8d | 30.8d | 0d | Shuttering Carpenter [400 h]; Common Labor / Helper [312 h]; Scaffolder [156 h] | 3,431.79 | 0 | 0 | 0.0015418111 | 6 | RPI - CONS | Z2 | PW | MECH | 1.3.3.30 | CONS | CONS | ZONE-3 | ROAD-2 | MECH | SEA-W |
| CON-Z3-UT-SW-NCL9-60 |  | Concrete pouring for base slab | 0.8d | 2017-07-16 | 2017-07-16 | CON-Z3-UT-SW-NCL9-70 | 30.8d | 0d | Concrete Mason [78 h]; Common Labor / Helper [62.4 h]; Finishing Work Crew [52 h]; Driver - Conc. Transit Mixers [10.4 h]; Operator - Concrete Pump [10.4 h] | 1,715.89 | 0 | 0 | 0.0015418111 | 6 | RPI - CONS | Z2 | PW | MECH | 1.3.3.30 | CONS | CONS | ZONE-3 | ROAD-2 | MECH | SEA-W |
| CON-Z3-UT-SW-NCL9-80 |  | Concrete pouring for Side Wall | 0.8d | 2017-07-17 | 2017-07-17 | CON-Z3-UT-SW-NCL9-60 | 30.8d | 0d | Concrete Mason [78 h]; Common Labor / Helper [62.4 h]; Finishing Work Crew [52 h]; Driver - Conc. Transit Mixers [10.4 h]; Operator - Concrete Pump [10.4 h] | 3,431.79 | 0 | 0 | 0.0040086961 | 6 | RPI - CONS | Z2 | PW | MECH | 1.3.3.30 | CONS | CONS | ZONE-3 | ROAD-2 | MECH | SEA-W |
| CON-Z3-UT-SW-NCL9-90 |  | Formwork removal and concrete patching | 1.6d | 2017-07-17 | 2017-07-19 | CON-Z3-UT-SW-NCL9-80 | 30.8d | 0d | Shuttering Carpenter [124.8 h]; Scaffolder [83.2 h]; Finishing Work Crew [52 h] | 686.36 | 0 | 0 | 0.0015418111 | 6 | RPI - CONS | Z2 | PW | MECH | 1.3.3.30 | CONS | CONS | ZONE-3 | ROAD-2 | MECH | SEA-W |
| CON-Z3-UT-SW-NCL9-92 |  | Concrete Supports | 0.8d | 2017-07-19 | 2017-07-20 | CON-Z3-UT-SW-NCL9-90 | 30.8d | 0d | Shuttering Carpenter [52 h]; Concrete Mason [41.6 h]; Common Labor / Helper [62.4 h] | 1,029.54 | 0 | 0 | 0.000616716 | 6 | RPI - CONS | Z2 | PW | MECH | 1.3.3.30 | CONS | CONS | ZONE-3 | ROAD-2 | MECH | SEA-W |
| CON-Z3-UT-SW-NCL9-91 |  | Installation of Pipe Connections / Closing of Openings | 3.2d | 2017-07-20 | 2017-07-24 | CON-Z3-UT-SW-NCL9-92 | 30.8d | 0d | Shuttering Carpenter [124.8 h]; Concrete Mason [166.4 h]; Plumber [208 h]; Common Labor / Helper [208 h] | 5,147.68 | 0 | 0 | 0.0055505071 | 6 | RPI - CONS | Z2 | PW | MECH | 1.3.3.30 | CONS | CONS | ZONE-3 | ROAD-2 | MECH | SEA-W |
| CON-Z3-UT-SW-VC-8420 |  | Installation of Dismantling joints | 2.4d | 2017-07-20 | 2017-07-23 | CON-Z3-UT-SW-NCL9-91 SS | 32.4d | 0d | Common Labor / Helper [187.2 h]; RTR Pipe Crew [62.4 h] | 2,402.25 |  |  |  |  |  |  |  |  | 1.3.3.30 | CONS | CONS | ZONE-3 | ROAD-2 | MECH | SEA-W |
| CON-Z3-UT-SW-VC-8430 |  | Installation of Valves | 4d | 2017-07-23 | 2017-07-27 | CON-Z3-UT-SW-VC-8420 | 32.4d | 1.6d | Common Labor / Helper [260 h]; RTR Pipe Crew [52 h] | 3,431.79 |  |  |  |  |  |  |  |  | 1.3.3.30 | CONS | CONS | ZONE-3 | ROAD-2 | MECH | SEA-W |
| CON-Z3-UT-SW-NCL9-93 |  | Damp Proof Coating | 0.8d | 2017-07-24 | 2017-07-25 | CON-Z3-UT-SW-NCL9-90, CON-Z3-UT-SW-NCL9-91 | 30.8d | 0d | Painter [52 h]; Water Proofing Crew [52 h] | 686.36 | 0 | 0 | 0.0015418111 | 6 | RPI - CONS | Z2 | PW | MECH | 1.3.3.30 | CONS | CONS | ZONE-3 | ROAD-2 | MECH | SEA-W |
| CON-Z3-UT-SW-NCL9-94 |  | Backfilling & Compaction | 4d | 2017-07-25 | 2017-07-30 | CON-Z3-UT-SW-NCL9-93 | 30.8d | 0d | Common Labor / Helper [260 h]; Driver - Dump Truck [52 h]; Operator - Bobcat [52 h]; Operator - Roller-Compactor (2~10 Ton) [52 h]; Driver - Water Tanker [52 h]; Operator - JCB [52 h]; Bobcat [56 h]; Plate Compactor [56 h]; Vibrators [56 h]; Water Tanker [56 h]; JCB [56 h] | 1,715.89 | 0 | 0 | 0.0037003381 | 6 | RPI - CONS | Z2 | PW | MECH | 1.3.3.30 | CONS | CONS | ZONE-3 | ROAD-2 | MECH | SEA-W |
| CON-Z3-UT-SW-VC-8440 |  | Installation of Roof Slab, Manhole Cover, Accessories & Finishes | 4d | 2017-07-30 | 2017-08-03 | CON-Z3-UT-SW-VC-8430, CON-Z3-UT-SW-NCL9-94, CON-Z3-UT-SW-VC-8470 SS | 30.8d | 0d | Common Labor / Helper [52 h]; Finishing Work Crew [52 h] | 2,745.43 |  |  |  |  |  |  |  |  | 1.3.3.30 | CONS | CONS | ZONE-3 | ROAD-2 | MECH | SEA-W |
|  | 1 | **Interfaces and Tie in Connections With Existing KAUST Utilities** |  | 2016-12-31 | 2017-03-01 |  |  |  |  |  |  |  |  |  |  |  |  |  |  |  |  |  |  |  |  |
| CON-SZ3-SEA-TIE-070 |  | Rd-5 Crossing Connections | 12d | 2016-12-31 | 2017-01-14 | CON-Z3-UT-SEA-PL-380 | 159.8d | 0d | Common Labor / Helper [52 h]; RTR Pipe Crew [26 h] | 8,579.46 |  |  |  |  |  |  |  |  | 1.3.3.30 | CONS | CONS | ZONE-3 | ROAD-5 | MECH | SEA-W |
| CON-SZ3-SEA-TIE-080 |  | Rd-4 Crossing Seawater Line | 12d | 2017-01-14 | 2017-01-28 | CON-SZ3-SEA-TIE-070 | 159.8d | 0d | Common Labor / Helper [312 h]; RTR Pipe Crew [156 h] | 6,863.57 |  |  |  |  |  |  |  |  | 1.3.3.30 | CONS | CONS | ZONE-3 | ROAD-4 | MECH | SEA-W |
| CON-SZ3-SEA-TIE-090 |  | Rd-1 Crossing Seawater Line | 12d | 2017-01-28 | 2017-02-11 | CON-SZ3-SEA-TIE-080 | 159.8d | 0d | Common Labor / Helper [312 h]; RTR Pipe Crew [156 h] | 8,579.46 |  |  |  |  |  |  |  |  | 1.3.3.30 | CONS | CONS | ZONE-3 | ROAD-1 | MECH | SEA-W |
| CON-SZ3-SEA-TIE-100 |  | Extension of Existing RO Plant interface with pipe at TIE-IN VB-NCL-23 near CUP Area | 16d | 2017-02-11 | 2017-03-01 | CON-SZ3-SEA-TIE-080, CON-SZ3-SEA-TIE-090 | 159.8d | 129d | Common Labor / Helper [1040 h]; RTR Pipe Crew [416 h]; Plumber [1248 h] | 10,295.36 |  |  |  |  |  |  |  |  | 1.3.3.30 | CONS | CONS | ZONE-3 |  | MECH | SEA-W |
|  | 4 | **Sanitary Sewer System** |  | 2016-11-27 | 2017-08-01 |  |  |  |  |  |  |  |  |  |  |  |  |  |  |  |  |  |  |  |  |
|  | 1 | **Sewer Gravity System** |  | 2016-11-27 | 2017-07-01 |  |  |  |  |  |  |  |  |  |  |  |  |  |  |  |  |  |  |  |  |
|  | 1 | **Gravity Sewer Lines** |  | 2016-11-27 | 2017-07-01 |  |  |  |  |  |  |  |  |  |  |  |  |  |  |  |  |  |  |  |  |
|  | 3 | **Gravity Line From SMH-19A-R3 TO SMH-07-RP (250mm upvc) = 982.46 Lm** |  | 2016-11-27 | 2017-02-01 |  |  |  |  |  |  |  |  |  |  |  |  |  |  |  |  |  |  |  |  |
| CON-Z3-UT-GRV-PL-150 |  | Excavation of Trench (38.56 Lm) | 0.8d | 2016-11-27 | 2016-11-27 | CON-CON-CON-CON-0010 FS+90d | 30.2d | 0d | Common Labor / Helper [4 h]; Operator - Excavator [4 h]; Driver - Dump Truck [4 h]; Operator - JCB [4 h]; Excavator [4 h]; Dump Truck [4 h] | 17,507.01 |  |  |  |  |  |  |  |  | 1.3.3.40 | CONS | CONS | ZONE-3 |  | MECH | SEWER |
| CON-Z3-UT-GRV-PL-160 |  | Compaction and Sand bedding ()38.56 Lm) | 0.8d | 2016-11-30 | 2016-12-01 | CON-Z3-UT-GRV-PL-150 SS+3.2d | 110d | 22.4d | Common Labor / Helper [52 h]; Operator - Loader [13 h]; Driver - Dump Truck [13 h]; Operator - Bobcat [13 h]; Operator - JCB [13 h] | 11,671.34 |  |  |  |  |  |  |  |  | 1.3.3.40 | CONS | CONS | ZONE-3 |  | MECH | SEWER |
| CON-Z3-UT-GRV-PL-170 |  | Pipe Laying (38.56 Lm) | 0.8d | 2016-12-29 | 2016-12-29 | CON-Z3-UT-GRV-PL-160 SS+2.4d, PR-Z4-UT-SS-205-0080 | 87.6d | 0d | Plumber [52 h]; Common Labor / Helper [52 h]; RTR Pipe Crew [26 h]; Operator - Mobile Crane [10.4 h]; Driver - Flat Bed Trailer [10.4 h]; Mobile Crane ( 25-60 Ton) [11.2 h]; Flat Bed Trailer [11.2 h] | 35,014.02 |  |  |  |  |  |  |  |  | 1.3.3.40 | CONS | CONS | ZONE-3 |  | MECH | SEWER |
| CON-Z3-UT-GRV-PL-180 |  | Installation of Thurst Block | 1d | 2017-01-03 | 2017-01-04 | CON-Z3-UT-GRV-PL-170 SS+4d, PR-Z3-CW-CW-26-0080 | 87.6d | 0d | Steel Fixer [26 h]; Shuttering Carpenter [52 h]; Concrete Mason [52 h]; Common Labor / Helper [52 h]; Driver - Conc. Transit Mixers [26 h]; Operator - Concrete Pump [26 h]; Concrete Transit Mixers [28 h]; Concrete Pump [28 h] | 11,671.34 |  |  |  |  |  |  |  |  | 1.3.3.40 | CONS | CONS | ZONE-3 |  | MECH | SEWER |
| CON-Z3-UT-GRV-PL-190 |  | Backfilling | 15d | 2017-01-04 | 2017-01-22 | CON-Z3-UT-GRV-PL-180, CON-Z3-UT-GRV-PL-170 | 87.6d | 0d | Common Labor / Helper [52 h]; Operator - Loader [13 h]; Driver - Dump Truck [13 h]; Operator - Bobcat [13 h]; Operator - Asphalt Compactor / Roller [13 h]; Operator - Roller-Compactor (2~10 Ton) [13 h]; Driver - Water Tanker [13 h]; Operator - JCB [13 h]; Loader [14 h]; Dump Truck [14 h]; Bobcat [14 h]; Roller-Compactor (2~10 Ton) [14 h]; Plate Compactor [14 h]; Vibrators [14 h]; Water Tanker [14 h]; JCB [14 h] | 17,507.01 |  |  |  |  |  |  |  |  | 1.3.3.40 | CONS | CONS | ZONE-3 |  | MECH | SEWER |
| CON-Z3-UT-GRV-PL-200 |  | Testing and Precommissioning | 9.6d | 2017-01-22 | 2017-02-01 | CON-Z3-UT-GRV-PL-190 | 87.6d | 0d | Plumber [52 h]; Common Labor / Helper [52 h]; RTR Pipe Crew [52 h]; Driver - Water Tanker [26 h]; Water Tanker [28 h] | 23,342.68 |  |  |  |  |  |  |  |  | 1.3.3.40 | CONS | CONS | ZONE-3 |  | MECH | SEWER |

Notes:
- CON-Z3-UT-SW-NCL9-10: Expenses: (New Expense Item) 1715.89
- CON-Z3-UT-SW-NCL9-20: Expenses: (New Expense Item) 1029.54
- CON-Z3-UT-SW-NCL9-50: Expenses: (New Expense Item) 1715.89
- CON-Z3-UT-SW-NCL9-30: Expenses: (New Expense Item) 1715.89
- CON-Z3-UT-SW-NCL9-40: Expenses: (New Expense Item) 1715.89
- CON-Z3-UT-SW-NCL9-70: Expenses: (New Expense Item) 3431.79
- CON-Z3-UT-SW-NCL9-60: Expenses: (New Expense Item) 1715.89
- CON-Z3-UT-SW-NCL9-80: Expenses: (New Expense Item) 3431.79
- CON-Z3-UT-SW-NCL9-90: Expenses: (New Expense Item) 686.36
- CON-Z3-UT-SW-NCL9-92: Expenses: (New Expense Item) 1029.54
- CON-Z3-UT-SW-NCL9-91: Expenses: (New Expense Item) 5147.68
- CON-Z3-UT-SW-VC-8420: Expenses: (New Expense Item) 2402.25
- CON-Z3-UT-SW-VC-8430: Expenses: (New Expense Item) 3431.79
- CON-Z3-UT-SW-NCL9-93: Expenses: (New Expense Item) 686.36
- CON-Z3-UT-SW-NCL9-94: Expenses: (New Expense Item) 1715.89
- CON-Z3-UT-SW-VC-8440: Expenses: (New Expense Item) 2745.43
- CON-SZ3-SEA-TIE-070: Expenses: (New Expense Item) 8579.46
- CON-SZ3-SEA-TIE-080: Expenses: (New Expense Item) 6863.57
- CON-SZ3-SEA-TIE-090: Expenses: (New Expense Item) 8579.46
- CON-SZ3-SEA-TIE-100: Expenses: (New Expense Item) 10295.4
- CON-Z3-UT-GRV-PL-150: Expenses: (New Expense Item) 17507
- CON-Z3-UT-GRV-PL-160: Expenses: (New Expense Item) 11671.3
- CON-Z3-UT-GRV-PL-170: Expenses: (New Expense Item) 35014
- CON-Z3-UT-GRV-PL-180: Expenses: (New Expense Item) 11671.3
- CON-Z3-UT-GRV-PL-190: Expenses: (New Expense Item) 17507
- CON-Z3-UT-GRV-PL-200: Expenses: (New Expense Item) 23342.7

| ID | WBS | Activity | Duration | Start | Finish | Predecessors | Total float | Free float | Resources | Cost | RPI_P2 - BOQ ITEMS | RPI_P2 - CONSTRUCTION | RPI_P2 - PHASE | RPI_P2 - ZONES | RPI_P2 - DISCIPLINE / WORK TYPE | RPI_P2 - UTILITY NETWORK |
| --- | --- | --- | --- | --- | --- | --- | --- | --- | --- | --- | --- | --- | --- | --- | --- | --- |
|  | 5 | **Gravity Line From SMH-07-RP TO LS#10 (300mm upvc) = 11.5 Lm** |  | 2016-12-04 | 2017-01-23 |  |  |  |  |  |  |  |  |  |  |  |
| CON-Z3-UT-GRV-PL-210 |  | Excavation of Trench | 0.8d | 2016-12-04 | 2016-12-04 | CON-Z3-UT-GRV-PL-150 FS+5d | 30.2d | 0d | Common Labor / Helper [39 h]; Driver - Dump Truck [13 h]; Operator - JCB [13 h]; Dump Truck [14 h]; JCB [11.2 h] | 6,669.34 | 1.3.3.40 | CONS | CONS | ZONE-3 | MECH | SEWER |
| CON-Z3-UT-GRV-PL-220 |  | Compaction and Sand bedding | 0.8d | 2016-12-07 | 2016-12-07 | CON-Z3-UT-GRV-PL-210 SS+3.2d | 45.2d | 0d | Common Labor / Helper [52 h]; Operator - Loader [10.4 h]; Driver - Dump Truck [10.4 h]; Operator - Bobcat [10.4 h]; Operator - JCB [10.4 h]; JCB [11.2 h]; Bobcat [11.2 h]; Loader [11.2 h] | 3,334.67 | 1.3.3.40 | CONS | CONS | ZONE-3 | MECH | SEWER |
| CON-Z3-UT-GRV-PL-230 |  | Pipe Laying | 0.8d | 2016-12-10 | 2016-12-11 | CON-Z3-UT-GRV-PL-220 SS+2.4d | 45.2d | 0d | Plumber [65 h]; Common Labor / Helper [39 h]; RTR Pipe Crew [26 h]; Operator - Mobile Crane [13 h]; Driver - Flat Bed Trailer [13 h]; Mobile Crane ( 25-60 Ton) [14 h]; Flat Bed Trailer [14 h]; Driver - Flat Bed Trailer [10.4 h] | 10,004.01 | 1.3.3.40 | CONS | CONS | ZONE-3 | MECH | SEWER |
| CON-Z3-UT-GRV-PL-240 |  | Backfilling | 0.8d | 2016-12-14 | 2016-12-15 | CON-Z3-UT-GRV-PL-230 SS+4d | 119.4d | 31.8d | Common Labor / Helper [52 h]; Operator - Loader [13 h]; Driver - Dump Truck [13 h]; Operator - Bobcat [13 h]; Operator - Asphalt Compactor / Roller [13 h]; Operator - Roller-Compactor (2~10 Ton) [13 h]; Driver - Water Tanker [13 h]; Operator - JCB [13 h]; Loader [14 h]; Dump Truck [14 h]; Bobcat [14 h]; Roller-Compactor (2~10 Ton) [14 h]; Plate Compactor [14 h]; Vibrators [14 h]; Water Tanker [14 h]; JCB [14 h] | 6,669.34 | 1.3.3.40 | CONS | CONS | ZONE-3 | MECH | SEWER |
| CON-Z3-UT-GRV-PL-250 |  | Testing and Precommissioning | 1.6d | 2017-01-22 | 2017-01-23 | CON-Z3-UT-GRV-PL-240, CON-Z3-UT-GRV-PL-230, CON-Z3-UT-GRV-PL-200 SS | 87.6d | 0d | Plumber [52 h]; Common Labor / Helper [52 h]; RTR Pipe Crew [52 h]; Driver - Water Tanker [26 h]; Water Tanker [28 h] | 6,669.34 | 1.3.3.40 | CONS | CONS | ZONE-3 | MECH | SEWER |
|  | 6 | **Gravity Line From SMH-06-R3 TO SMH-05-R4 (250mm upvc) = 418.6 Lm** |  | 2016-12-11 | 2017-02-05 |  |  |  |  |  |  |  |  |  |  |  |
| CON-Z3-UT-GRV-PL-260 |  | Remaining Work for Construction of Gravity Line From SMH-06-R3 TO SMH-05-R4 (250mm upvc)) | 8d | 2016-12-11 | 2016-12-20 | CON-Z3-UT-GRV-PL-230 | 45.2d | 0d | JCB [112 h]; Common Labor / Helper [1560 h]; Plumber [1040 h]; Common Labor / Helper [104 h]; Operator - Loader [104 h]; Driver - Dump Truck [104 h]; Operator - Bobcat [104 h]; Operator - Roller-Compactor (2~10 Ton) [104 h]; Operator - JCB [104 h]; Loader [112 h]; Dump Truck [112 h]; Bobcat [112 h]; Roller-Compactor (2~10 Ton) [112 h]; Plate Compactor [112 h]; Vibrators [112 h]; Water Tanker [112 h]; Air-Compressor 300/900 CFM + Hummer [112 h]; Tower Light [112 h]; Boom Truck (15 Ton) [112 h] | 70,028.04 | 1.3.3.40 | CONS | CONS | ZONE-3 | MECH | SEWER |
| CON-Z3-UT-GRV-PL-270 |  | Testing and Precommissioning | 12d | 2017-01-22 | 2017-02-05 | CON-Z3-UT-GRV-PL-260, CON-Z3-UT-GRV-PL-250 SS | 87.6d | 0d | RTR Pipe Crew [52 h]; Driver - Water Tanker [26 h]; Water Tanker [28 h]; Plumber [52 h]; Common Labor / Helper [52 h] | 46,685.36 | 1.3.3.40 | CONS | CONS | ZONE-3 | MECH | SEWER |
|  | 7 | **Gravity Line From SMH-01-R4 TO SMH-10-R3 (200mm upvc) = 346.6 Lm** |  | 2016-12-20 | 2017-02-16 |  |  |  |  |  |  |  |  |  |  |  |
| CON-Z3-UT-GRV-PL-280 |  | Remaining Work for Construction of Gravity Line From SMH-01-R4 TO SMH-10-R3 (200mm upvc) | 8d | 2016-12-20 | 2016-12-29 | CON-Z3-UT-GRV-PL-260 | 45.2d | 0d | Plumber [520 h]; Common Labor / Helper [1560 h]; Operator - Loader [104 h]; Driver - Dump Truck [104 h]; Operator - Bobcat [104 h]; Operator - Roller-Compactor (2~10 Ton) [104 h]; Operator - JCB [104 h]; Loader [112 h]; Dump Truck [112 h]; Bobcat [112 h]; Roller-Compactor (2~10 Ton) [112 h]; Plate Compactor [112 h]; Vibrators [112 h]; Water Tanker [112 h]; Air-Compressor 300/900 CFM + Hummer [112 h]; Tower Light [112 h]; Boom Truck (15 Ton) [112 h]; JCB [112 h] | 60,024.04 | 1.3.3.40 | CONS | CONS | ZONE-3 | MECH | SEWER |
| CON-Z3-UT-GRV-PL-290 |  | Testing and Precommissioning | 10d | 2017-02-05 | 2017-02-16 | CON-Z3-UT-GRV-PL-280, CON-Z3-UT-GRV-PL-270 | 87.6d | 0d | Plumber [520 h]; Common Labor / Helper [780 h]; RTR Pipe Crew [260 h]; Driver - Water Tanker [100 h]; Water Tanker [140 h] | 40,016.02 | 1.3.3.40 | CONS | CONS | ZONE-3 | MECH | SEWER |
|  | 8 | **Gravity Line From SMH-02-RA TO SMH-07-RP (200mm upvc) = 830.63 Lm** |  | 2016-12-29 | 2017-03-06 |  |  |  |  |  |  |  |  |  |  |  |
| CON-Z3-UT-GRV-PL-300 |  | Remaining Work for Construction of Gravity Line From SMH-02-RA TO SMH-07-RP (200mm upvc) | 16d | 2016-12-29 | 2017-01-17 | CON-Z3-UT-GRV-PL-280 | 45.2d | 0d | Plumber [1040 h]; Common Labor / Helper [208 h]; Operator - Loader [208 h]; Driver - Dump Truck [208 h]; Operator - Bobcat [208 h]; Operator - Roller-Compactor (2~10 Ton) [208 h]; Operator - JCB [208 h]; Loader [224 h]; Dump Truck [224 h]; Bobcat [224 h]; Roller-Compactor (2~10 Ton) [224 h]; Plate Compactor [224 h]; Vibrators [224 h]; Water Tanker [224 h]; Air-Compressor 300/900 CFM + Hummer [224 h]; Tower Light [224 h]; Boom Truck (15 Ton) [224 h]; JCB [224 h] | 100,040.06 | 1.3.3.40 | CONS | CONS | ZONE-3 | MECH | SEWER |
| CON-Z3-UT-GRV-PL-310 |  | Testing and Precommissioning | 15d | 2017-02-16 | 2017-03-06 | CON-Z3-UT-GRV-PL-290, CON-Z3-UT-GRV-PL-300 | 87.6d | 0d | Plumber [1170 h]; Common Labor / Helper [780 h]; RTR Pipe Crew [150 h]; Driver - Water Tanker [150 h]; Water Tanker [210 h] | 66,693.37 | 1.3.3.40 | CONS | CONS | ZONE-3 | MECH | SEWER |
|  | 9 | **Gravity Line From SMH-14-R2 TO SMH-07-RP (200mm upvc) = 664.5 Lm** |  | 2017-01-17 | 2017-03-23 |  |  |  |  |  |  |  |  |  |  |  |
| CON-Z3-UT-GRV-PL-320 |  | Remaining Work for Construction of Gravity Line From SMH-14-R2 TO SMH-07-RP (200mm upvc) | 14.4d | 2017-01-17 | 2017-02-02 | CON-Z3-UT-GRV-PL-300 | 45.2d | 0d | Plumber [52 h]; Common Labor / Helper [104 h]; Operator - Loader [26 h]; Driver - Dump Truck [26 h]; Operator - Bobcat [26 h]; Operator - Roller-Compactor (2~10 Ton) [26 h]; Operator - JCB [26 h]; Loader [28 h]; Dump Truck [28 h]; Bobcat [28 h]; Roller-Compactor (2~10 Ton) [28 h]; Plate Compactor [28 h]; Vibrators [28 h]; Water Tanker [28 h]; Air-Compressor 300/900 CFM + Hummer [28 h]; Tower Light [28 h]; Boom Truck (15 Ton) [28 h]; JCB [28 h] | 90,036.05 | 1.3.3.40 | CONS | CONS | ZONE-3 | MECH | SEWER |
| CON-Z3-UT-GRV-PL-330 |  | Testing and Precommissioning | 15d | 2017-03-06 | 2017-03-23 | CON-Z3-UT-GRV-PL-310, CON-Z3-UT-GRV-PL-320 | 87.6d | 0d | Plumber [750 h]; Common Labor / Helper [52 h]; RTR Pipe Crew [52 h]; Driver - Water Tanker [26 h]; Water Tanker [28 h] | 60,024.04 | 1.3.3.40 | CONS | CONS | ZONE-3 | MECH | SEWER |
|  | 10 | **Gravity Line From SMH-RL-01 TO SMH-08-R4 (200mm upvc) = 217.8 Lm** |  | 2017-02-02 | 2017-04-04 |  |  |  |  |  |  |  |  |  |  |  |
| CON-Z3-UT-GRV-PL-340 |  | Remaining Work for Construction of Gravity Line From SMH-RL-01 TO SMH-08-R4 (200mm upvc) | 6.4d | 2017-02-02 | 2017-02-11 | CON-Z3-UT-GRV-PL-320 | 45.4d | 0d | Plumber [52 h]; Common Labor / Helper [832 h]; Operator - Loader [64 h]; Driver - Dump Truck [64 h]; Operator - Bobcat [64 h]; Operator - Roller-Compactor (2~10 Ton) [64 h]; Operator - JCB [64 h]; Loader [89.6 h]; Dump Truck [89.6 h]; Bobcat [89.6 h]; Roller-Compactor (2~10 Ton) [89.6 h]; Plate Compactor [89.6 h]; Vibrators [89.6 h]; Water Tanker [89.6 h]; Air-Compressor 300/900 CFM + Hummer [89.6 h]; Tower Light [89.6 h]; Boom Truck (15 Ton) [89.6 h]; JCB [89.6 h] | 60,024.04 | 1.3.3.40 | CONS | CONS | ZONE-3 | MECH | SEWER |
| CON-Z3-UT-GRV-PL-350 |  | Testing and Precommissioning | 10d | 2017-03-23 | 2017-04-04 | CON-Z3-UT-GRV-PL-330, CON-Z3-UT-GRV-PL-340 | 87.6d | 0d | Plumber [52 h]; Common Labor / Helper [52 h]; RTR Pipe Crew [52 h]; Driver - Water Tanker [26 h]; Water Tanker [28 h] | 40,016.02 | 1.3.3.40 | CONS | CONS | ZONE-3 | MECH | SEWER |
|  | 11 | **Gravity Line From SMH-RL-06A TO SMH-08-R4 (200mm upvc) = 257.8 Lm** |  | 2017-02-11 | 2017-04-04 |  |  |  |  |  |  |  |  |  |  |  |
| CON-Z3-UT-GRV-PL-360 |  | Remaining Work for Construction of Gravity Line From SMH-RL-06A TO SMH-08-R4 (200mm upvc) | 6.4d | 2017-02-11 | 2017-02-18 | CON-Z3-UT-GRV-PL-340 | 45.4d | 0d | Plumber [52 h]; Common Labor / Helper [832 h]; Operator - Loader [64 h]; Driver - Dump Truck [64 h]; Operator - Bobcat [64 h]; Operator - Roller-Compactor (2~10 Ton) [64 h]; Operator - JCB [64 h]; Loader [89.6 h]; Dump Truck [89.6 h]; Bobcat [89.6 h]; Roller-Compactor (2~10 Ton) [89.6 h]; Plate Compactor [89.6 h]; Vibrators [89.6 h]; Water Tanker [89.6 h]; Air-Compressor 300/900 CFM + Hummer [89.6 h]; Tower Light [89.6 h]; Boom Truck (15 Ton) [896 h]; JCB [89.6 h] | 60,024.04 | 1.3.3.40 | CONS | CONS | ZONE-3 | MECH | SEWER |
| CON-Z3-UT-GRV-PL-370 |  | Testing and Precommissioning | 10d | 2017-03-23 | 2017-04-04 | CON-Z3-UT-GRV-PL-360, CON-Z3-UT-GRV-PL-350 SS | 87.6d | 0d | Plumber [52 h]; Common Labor / Helper [52 h]; RTR Pipe Crew [52 h]; Driver - Water Tanker [26 h]; Water Tanker [28 h] | 40,016.02 | 1.3.3.40 | CONS | CONS | ZONE-3 | MECH | SEWER |

Notes:
- CON-Z3-UT-GRV-PL-210: Expenses: (New Expense Item) 6669.34
- CON-Z3-UT-GRV-PL-220: Expenses: (New Expense Item) 3334.67
- CON-Z3-UT-GRV-PL-230: Expenses: (New Expense Item) 10004
- CON-Z3-UT-GRV-PL-240: Expenses: (New Expense Item) 6669.34
- CON-Z3-UT-GRV-PL-250: Expenses: (New Expense Item) 6669.34
- CON-Z3-UT-GRV-PL-260: Expenses: (New Expense Item) 70028
- CON-Z3-UT-GRV-PL-270: Expenses: (New Expense Item) 46685.4
- CON-Z3-UT-GRV-PL-280: Expenses: (New Expense Item) 60024
- CON-Z3-UT-GRV-PL-290: Expenses: (New Expense Item) 40016
- CON-Z3-UT-GRV-PL-300: Expenses: (New Expense Item) 100040
- CON-Z3-UT-GRV-PL-310: Expenses: (New Expense Item) 66693.4
- CON-Z3-UT-GRV-PL-320: Expenses: (New Expense Item) 90036.1
- CON-Z3-UT-GRV-PL-330: Expenses: (New Expense Item) 60024
- CON-Z3-UT-GRV-PL-340: Expenses: (New Expense Item) 60024
- CON-Z3-UT-GRV-PL-350: Expenses: (New Expense Item) 40016
- CON-Z3-UT-GRV-PL-360: Expenses: (New Expense Item) 60024
- CON-Z3-UT-GRV-PL-370: Expenses: (New Expense Item) 40016

| ID | WBS | Activity | Duration | Start | Finish | Predecessors | Total float | Free float | Resources | Cost | RPI_P2 - BOQ ITEMS | RPI_P2 - CONSTRUCTION | RPI_P2 - PHASE | RPI_P2 - ZONES | RPI_P2 - DISCIPLINE / WORK TYPE | RPI_P2 - UTILITY NETWORK |
| --- | --- | --- | --- | --- | --- | --- | --- | --- | --- | --- | --- | --- | --- | --- | --- | --- |
|  | 12 | **Gravity Line From SMH-08-RA TO SMH-01-RP (200mm upvc) = 220.83 Lm** |  | 2017-02-18 | 2017-04-04 |  |  |  |  |  |  |  |  |  |  |  |
| CON-Z3-UT-GRV-PL-380 |  | Remaining Work for Construction of Gravity Line From SMH-08-RA TO SMH-01-RP (200mm upvc) | 6.4d | 2017-02-18 | 2017-02-25 | CON-Z3-UT-GRV-PL-360 | 45.4d | 0d | Plumber [52 h]; Common Labor / Helper [832 h]; Operator - Loader [26 h]; Driver - Dump Truck [26 h]; Operator - Bobcat [26 h]; Operator - Roller-Compactor (2~10 Ton) [26 h]; Operator - JCB [26 h]; Loader [28 h]; Dump Truck [28 h]; Bobcat [28 h]; Roller-Compactor (2~10 Ton) [28 h]; Plate Compactor [28 h]; Vibrators [28 h]; Water Tanker [28 h]; Boom Truck (15 Ton) [28 h]; JCB [28 h]; Air-Compressor 300/900 CFM + Hummer [28 h]; Tower Light [28 h] | 60,024.04 | 1.3.3.40 | CONS | CONS | ZONE-3 | MECH | SEWER |
| CON-Z3-UT-GRV-PL-390 |  | Testing and Precommissioning | 10d | 2017-03-23 | 2017-04-04 | CON-Z3-UT-GRV-PL-380, CON-Z3-UT-GRV-PL-370 SS | 87.6d | 0d | Plumber [52 h]; Common Labor / Helper [52 h]; RTR Pipe Crew [52 h]; Driver - Water Tanker [26 h]; Water Tanker [28 h] | 40,016.02 | 1.3.3.40 | CONS | CONS | ZONE-3 | MECH | SEWER |
|  | 13 | **Gravity Line From SMH-RL-12 TO SMH-RL-03 (200mm upvc) = 63 Lm** |  | 2017-02-26 | 2017-03-26 |  |  |  |  |  |  |  |  |  |  |  |
| CON-Z3-UT-GRV-PL-400 |  | Remaining Work for Construction of Gravity Line From SMH-RL-12 TO SMH-RL-03 (200mm upvc) | 2.4d | 2017-02-26 | 2017-02-28 | CON-Z3-UT-GRV-PL-380 | 45.4d | 0d | Boom Truck (15 Ton) [28 h]; JCB [28 h]; Plumber [52 h]; Common Labor / Helper [312 h]; Operator - Loader [26 h]; Driver - Dump Truck [26 h]; Operator - Bobcat [26 h]; Operator - Roller-Compactor (2~10 Ton) [26 h]; Operator - JCB [26 h]; Loader [28 h]; Dump Truck [28 h]; Bobcat [28 h]; Roller-Compactor (2~10 Ton) [28 h]; Plate Compactor [28 h]; Vibrators [28 h]; Water Tanker [28 h]; Air-Compressor 300/900 CFM + Hummer [28 h]; Tower Light [28 h] | 30,012.02 | 1.3.3.40 | CONS | CONS | ZONE-3 | MECH | SEWER |
| CON-Z3-UT-GRV-PL-410 |  | Testing and Precommissioning | 2d | 2017-03-23 | 2017-03-26 | CON-Z3-UT-GRV-PL-400, CON-Z3-UT-GRV-PL-390 SS | 87.6d | 0d | Plumber [100 h]; Common Labor / Helper [52 h]; RTR Pipe Crew [52 h]; Driver - Water Tanker [26 h]; Water Tanker [28 h] | 20,008.01 | 1.3.3.40 | CONS | CONS | ZONE-3 | MECH | SEWER |
|  | 14 | **Gravity Line From SMH-01-R2 TO LS#11 (250mm upvc) = 295.2 Lm** |  | 2017-02-28 | 2017-04-04 |  |  |  |  |  |  |  |  |  |  |  |
| CON-Z3-UT-GRV-PL-420 |  | Remaining Work for Construction of Gravity Line From SMH-01-R2 TO LS#11 (250mm upvc) | 8d | 2017-02-28 | 2017-03-09 | CON-Z3-UT-GRV-PL-400 | 45.4d | 0d | Plumber [52 h]; Common Labor / Helper [104 h]; Operator - Loader [26 h]; Driver - Dump Truck [26 h]; Operator - Bobcat [26 h]; Operator - Roller-Compactor (2~10 Ton) [26 h]; Operator - JCB [26 h]; Loader [28 h]; Dump Truck [28 h]; Bobcat [28 h]; Roller-Compactor (2~10 Ton) [28 h]; Plate Compactor [28 h]; Vibrators [28 h]; Water Tanker [28 h]; Air-Compressor 300/900 CFM + Hummer [28 h]; Tower Light [28 h]; Boom Truck (15 Ton) [28 h]; JCB [28 h] | 60,024.04 | 1.3.3.40 | CONS | CONS | ZONE-3 | MECH | SEWER |
| CON-Z3-UT-GRV-PL-430 |  | Testing and Precommissioning | 10d | 2017-03-23 | 2017-04-04 | CON-Z3-UT-GRV-PL-420, CON-Z3-UT-GRV-PL-410 SS | 87.6d | 0d | Plumber [52 h]; Common Labor / Helper [52 h]; RTR Pipe Crew [52 h]; Driver - Water Tanker [26 h]; Water Tanker [28 h] | 40,016.02 | 1.3.3.40 | CONS | CONS | ZONE-3 | MECH | SEWER |
|  | 15 | **Gravity Line From SMH-RL-9A TO SMH-RL-09 (200mm upvc) = 40 Lm** |  | 2017-03-09 | 2017-03-26 |  |  |  |  |  |  |  |  |  |  |  |
| CON-Z3-UT-GRV-PL-440 |  | Remaining Work for Construction of Gravity Line From SMH-RL-9A TO SMH-RL-09 (200mm upvc) | 1.6d | 2017-03-09 | 2017-03-11 | CON-Z3-UT-GRV-PL-420 | 45.4d | 0d | Plumber [52 h]; Common Labor / Helper [41.6 h]; Operator - Loader [26 h]; Driver - Dump Truck [26 h]; Operator - Bobcat [26 h]; Operator - Roller-Compactor (2~10 Ton) [26 h]; Operator - JCB [26 h]; Loader [28 h]; Dump Truck [28 h]; Bobcat [28 h]; Roller-Compactor (2~10 Ton) [28 h]; Plate Compactor [28 h]; Vibrators [28 h]; Water Tanker [28 h]; Air-Compressor 300/900 CFM + Hummer [28 h]; Tower Light [28 h]; Boom Truck (15 Ton) [28 h]; JCB [28 h] | 30,012.02 | 1.3.3.40 | CONS | CONS | ZONE-3 | MECH | SEWER |
| CON-Z3-UT-GRV-PL-450 |  | Testing and Precommissioning | 2d | 2017-03-23 | 2017-03-26 | CON-Z3-UT-GRV-PL-430 SS, CON-Z3-UT-GRV-PL-440 | 87.6d | 6.6d | Plumber [120 h]; Common Labor / Helper [52 h]; RTR Pipe Crew [52 h]; Driver - Water Tanker [26 h]; Water Tanker [28 h] | 20,008.01 | 1.3.3.40 | CONS | CONS | ZONE-3 | MECH | SEWER |
|  | 16 | **Gravity Line From SMH-10-R2 TO SMH-01-R2 (200mm upvc) = 778.8 Lm** |  | 2017-03-12 | 2017-04-17 |  |  |  |  |  |  |  |  |  |  |  |
| CON-Z3-UT-GRV-PL-460 |  | Remaining Work for Construction of Gravity Line From SMH-10-R2 TO SMH-01-R2 (200mm upvc) | 16d | 2017-03-12 | 2017-03-30 | CON-Z3-UT-GRV-PL-440 SS+2.4d | 45.4d | 0d | Plumber [52 h]; Common Labor / Helper [104 h]; Operator - Bobcat [26 h]; Operator - Roller-Compactor (2~10 Ton) [26 h]; Operator - JCB [26 h]; Loader [28 h]; Dump Truck [28 h]; Bobcat [28 h]; Roller-Compactor (2~10 Ton) [28 h]; Plate Compactor [28 h]; Vibrators [28 h]; Water Tanker [28 h]; Air-Compressor 300/900 CFM + Hummer [28 h]; Tower Light [28 h]; Boom Truck (15 Ton) [28 h]; JCB [28 h]; Operator - Loader [26 h]; Driver - Dump Truck [26 h] | 80,032.05 | 1.3.3.40 | CONS | CONS | ZONE-3 | MECH | SEWER |
| CON-Z3-UT-GRV-PL-470 |  | Testing and Precommissioning | 15d | 2017-03-30 | 2017-04-17 | CON-Z3-UT-GRV-PL-450 SS, CON-Z3-UT-GRV-PL-460 | 81d | 0d | Plumber [52 h]; Common Labor / Helper [52 h]; RTR Pipe Crew [52 h]; Driver - Water Tanker [26 h]; Water Tanker [28 h] | 53,354.7 | 1.3.3.40 | CONS | CONS | ZONE-3 | MECH | SEWER |
|  | 17 | **Gravity Line From SMH-RL-16 TO SMH-29-RA (200mm upvc) = 340.04 Lm** |  | 2017-03-30 | 2017-05-13 |  |  |  |  |  |  |  |  |  |  |  |
| CON-Z3-UT-GRV-PL-480 |  | Remaining Work for Construction of Gravity Line From SMH-RL-16 TO SMH-29-RA (200mm upvc) | 9.6d | 2017-03-30 | 2017-04-11 | CON-Z3-UT-GRV-PL-460 | 45.4d | 0d | Plumber [52 h]; Common Labor / Helper [104 h]; Operator - Loader [26 h]; Driver - Dump Truck [26 h]; Operator - Bobcat [26 h]; Operator - Roller-Compactor (2~10 Ton) [26 h]; Operator - JCB [26 h]; Loader [28 h]; Dump Truck [28 h]; Bobcat [28 h]; Roller-Compactor (2~10 Ton) [28 h]; Plate Compactor [28 h]; Vibrators [28 h]; Water Tanker [28 h]; Air-Compressor 300/900 CFM + Hummer [28 h]; Tower Light [28 h]; Boom Truck (15 Ton) [28 h]; JCB [28 h] | 40,016.02 | 1.3.3.40 | CONS | CONS | ZONE-3 | MECH | SEWER |
| CON-Z3-UT-GRV-PL-490 |  | Testing and Precommissioning | 10d | 2017-05-01 | 2017-05-13 | CON-Z3-UT-GRV-PL-470 FS+12d, CON-Z3-UT-GRV-PL-480 | 81d | 0d | Common Labor / Helper [52 h]; RTR Pipe Crew [52 h]; Driver - Water Tanker [100 h]; Water Tanker [140 h]; Plumber [52 h] | 26,677.35 | 1.3.3.40 | CONS | CONS | ZONE-3 | MECH | SEWER |
|  | 18 | **Gravity Line From SMH-RL-7A TO SMH-RL-07 (200mm upvc) = 13 Lm** |  | 2017-05-04 | 2017-05-14 |  |  |  |  |  |  |  |  |  |  |  |
| CON-Z3-UT-GRV-PL-500 |  | Remaining Work for Construction of Gravity Line From SMH-RL-7A TO SMH-RL-07 (200mm upvc) | 1.6d | 2017-05-04 | 2017-05-06 | CON-Z3-UT-GRV-PL-480 FS+20d | 45.4d | 0d | Plumber [52 h]; Common Labor / Helper [104 h]; Operator - Loader [26 h]; Driver - Dump Truck [26 h]; Operator - Bobcat [26 h]; Operator - Roller-Compactor (2~10 Ton) [26 h]; Operator - JCB [26 h]; Loader [28 h]; Dump Truck [28 h]; Bobcat [28 h]; Roller-Compactor (2~10 Ton) [28 h]; Plate Compactor [28 h]; Vibrators [28 h]; Water Tanker [28 h]; Air-Compressor 300/900 CFM + Hummer [28 h]; Tower Light [28 h]; Boom Truck (15 Ton) [28 h]; JCB [28 h] | 10,004.01 | 1.3.3.40 | CONS | CONS | ZONE-3 | MECH | SEWER |
| CON-Z3-UT-GRV-PL-510 |  | Testing and Precommissioning | 1d | 2017-05-13 | 2017-05-14 | CON-Z3-UT-GRV-PL-500, CON-Z3-UT-GRV-PL-490 | 81d | 0d | Plumber [52 h]; Common Labor / Helper [52 h]; RTR Pipe Crew [52 h]; Driver - Water Tanker [26 h]; Water Tanker [28 h] | 6,669.34 | 1.3.3.40 | CONS | CONS | ZONE-3 | MECH | SEWER |
|  | 19 | **Gravity Line From SMH-25A-RA TO SMH-25-RA (200mm upvc) = 9 Lm** |  | 2017-05-04 | 2017-05-14 |  |  |  |  |  |  |  |  |  |  |  |
| CON-Z3-UT-GRV-PL-520 |  | Remaining Work for Construction of Gravity Line From SMH-25A-RA TO SMH-25-RA (200mm upvc) | 1.6d | 2017-05-04 | 2017-05-06 | CON-Z3-UT-GRV-PL-500 SS | 45.4d | 0d | Plumber [52 h]; Common Labor / Helper [104 h]; Operator - Loader [26 h]; Driver - Dump Truck [26 h]; Operator - Bobcat [26 h]; Operator - Roller-Compactor (2~10 Ton) [26 h]; Operator - JCB [26 h]; Loader [28 h]; Dump Truck [28 h]; Bobcat [28 h]; Roller-Compactor (2~10 Ton) [28 h]; Plate Compactor [28 h]; Vibrators [28 h]; Water Tanker [28 h]; Air-Compressor 300/900 CFM + Hummer [28 h]; Tower Light [28 h]; Boom Truck (15 Ton) [28 h]; JCB [28 h] | 10,004.01 | 1.3.3.40 | CONS | CONS | ZONE-3 | MECH | SEWER |
| CON-Z3-UT-GRV-PL-530 |  | Testing and Precommissioning | 1d | 2017-05-13 | 2017-05-14 | CON-Z3-UT-GRV-PL-510 SS, CON-Z3-UT-GRV-PL-520 | 81d | 0d | Plumber [52 h]; Common Labor / Helper [52 h]; RTR Pipe Crew [52 h]; Driver - Water Tanker [26 h]; Water Tanker [28 h] | 6,669.34 | 1.3.3.40 | CONS | CONS | ZONE-3 | MECH | SEWER |

Notes:
- CON-Z3-UT-GRV-PL-380: Expenses: (New Expense Item) 60024
- CON-Z3-UT-GRV-PL-390: Expenses: (New Expense Item) 40016
- CON-Z3-UT-GRV-PL-400: Expenses: (New Expense Item) 30012
- CON-Z3-UT-GRV-PL-410: Expenses: (New Expense Item) 20008
- CON-Z3-UT-GRV-PL-420: Expenses: (New Expense Item) 60024
- CON-Z3-UT-GRV-PL-430: Expenses: (New Expense Item) 40016
- CON-Z3-UT-GRV-PL-440: Expenses: (New Expense Item) 30012
- CON-Z3-UT-GRV-PL-450: Expenses: (New Expense Item) 20008
- CON-Z3-UT-GRV-PL-460: Expenses: (New Expense Item) 80032.1
- CON-Z3-UT-GRV-PL-470: Expenses: (New Expense Item) 53354.7
- CON-Z3-UT-GRV-PL-480: Expenses: (New Expense Item) 40016
- CON-Z3-UT-GRV-PL-490: Expenses: (New Expense Item) 26677.3
- CON-Z3-UT-GRV-PL-500: Expenses: (New Expense Item) 10004
- CON-Z3-UT-GRV-PL-510: Expenses: (New Expense Item) 6669.34
- CON-Z3-UT-GRV-PL-520: Expenses: (New Expense Item) 10004
- CON-Z3-UT-GRV-PL-530: Expenses: (New Expense Item) 6669.34

| ID | WBS | Activity | Duration | Start | Finish | Predecessors | Total float | Free float | Resources | Cost | RPI_P2 - BOQ ITEMS | RPI_P2 - CONSTRUCTION | RPI_P2 - PHASE | RPI_P2 - ZONES | RPI_P2 - DISCIPLINE / WORK TYPE | RPI_P2 - UTILITY NETWORK | RPI_P2 - AREAS |
| --- | --- | --- | --- | --- | --- | --- | --- | --- | --- | --- | --- | --- | --- | --- | --- | --- | --- |
|  | 20 | **Gravity Line From SMH-05A-R3 TO SMH-28-RA (200mm upvc) = 743.10 Lm** |  | 2017-05-13 | 2017-06-17 |  |  |  |  |  |  |  |  |  |  |  |  |
| CON-Z3-UT-GRV-PL-550 |  | Testing and Precommissioning | 20d | 2017-05-13 | 2017-06-05 | CON-Z3-UT-GRV-PL-530 SS | 81d | 31.8d | Plumber [52 h]; Common Labor / Helper [200 h]; RTR Pipe Crew [52 h]; Driver - Water Tanker [200 h]; Water Tanker [280 h] | 46,685.36 | 1.3.3.40 | CONS | CONS | ZONE-3 | MECH | SEWER |  |
| CON-Z3-UT-GRV-PL-540 |  | Remaining Work for Construction of Gravity Line From SMH-05A-R3 TO SMH-28-RA (200mm upvc) | 16d | 2017-05-30 | 2017-06-17 | CON-Z3-UT-GRV-PL-520 FS+20d | 45.4d | 0d | Plumber [52 h]; Common Labor / Helper [104 h]; Operator - Loader [26 h]; Driver - Dump Truck [26 h]; Operator - Bobcat [26 h]; Operator - Roller-Compactor (2~10 Ton) [26 h]; Operator - JCB [26 h]; Loader [28 h]; Dump Truck [28 h]; Bobcat [28 h]; Roller-Compactor (2~10 Ton) [28 h]; Plate Compactor [28 h]; Vibrators [28 h]; Water Tanker [28 h]; Air-Compressor 300/900 CFM + Hummer [28 h]; Tower Light [28 h]; Boom Truck (15 Ton) [28 h]; JCB [28 h] | 70,028.04 | 1.3.3.40 | CONS | CONS | ZONE-3 | MECH | SEWER |  |
|  | 21 | **Gravity Line From 07A-RA TO 07-RA (200mm upvc) = 36 Lm (Road Crossing)** |  | 2017-06-18 | 2017-06-20 |  |  |  |  |  |  |  |  |  |  |  |  |
| CON-Z3-UT-GRV-PL-560 |  | Remaining Work for Construction of Gravity Line From 07A-RA TO 07-RA (200mm upvc) | 1.6d | 2017-06-18 | 2017-06-19 | CON-Z3-UT-GRV-PL-540 | 45.4d | 0d | Plumber [52 h]; Common Labor / Helper [160 h]; Operator - Loader [26 h]; Driver - Dump Truck [26 h]; Operator - Bobcat [26 h]; Operator - Roller-Compactor (2~10 Ton) [26 h]; Operator - JCB [26 h]; Bobcat [28 h]; Roller-Compactor (2~10 Ton) [28 h]; Plate Compactor [28 h]; Vibrators [28 h]; Water Tanker [28 h]; Air-Compressor 300/900 CFM + Hummer [28 h]; Tower Light [28 h]; Boom Truck (15 Ton) [28 h]; JCB [28 h]; Loader [28 h]; Dump Truck [28 h] | 20,008.01 | 1.3.3.40 | CONS | CONS | ZONE-3 | MECH | SEWER |  |
| CON-Z3-UT-GRV-PL-570 |  | Testing and Precommissioning | 1d | 2017-06-19 | 2017-06-20 | CON-Z3-UT-GRV-PL-560, CON-Z3-UT-GRV-PL-550 SS | 49.2d | 1.6d | Plumber [100 h]; Common Labor / Helper [50 h]; RTR Pipe Crew [60 h]; Driver - Water Tanker [26 h]; Water Tanker [28 h] | 13,338.67 | 1.3.3.40 | CONS | CONS | ZONE-3 | MECH | SEWER |  |
|  | 22 | **Gravity Line From 12B-R2 TO 12-R2 (200mm upvc) = 36 Lm (Road Crossing)** |  | 2017-06-19 | 2017-06-22 |  |  |  |  |  |  |  |  |  |  |  |  |
| CON-Z3-UT-GRV-PL-580 |  | Remaining Work for Construction of Gravity Line From 12B-R2 TO 12-R2 (200mm upvc) | 1.6d | 2017-06-19 | 2017-06-21 | CON-Z3-UT-GRV-PL-560 | 45.4d | 0d | Plumber [52 h]; Common Labor / Helper [32 h]; Operator - Loader [26 h]; Driver - Dump Truck [26 h]; Operator - Bobcat [26 h]; Operator - Roller-Compactor (2~10 Ton) [26 h]; Operator - JCB [26 h]; Loader [28 h]; Dump Truck [28 h]; Bobcat [28 h]; Roller-Compactor (2~10 Ton) [28 h]; Plate Compactor [28 h]; Vibrators [28 h]; Water Tanker [28 h]; Air-Compressor 300/900 CFM + Hummer [28 h]; Tower Light [28 h]; Boom Truck (15 Ton) [28 h]; JCB [28 h] | 20,008.01 | 1.3.3.40 | CONS | CONS | ZONE-3 | MECH | SEWER |  |
| CON-Z3-UT-GRV-PL-590 |  | Testing and Precommissioning | 1d | 2017-06-21 | 2017-06-22 | CON-Z3-UT-GRV-PL-580, CON-Z3-UT-GRV-PL-570 SS | 47.6d | 1.6d | Plumber [52 h]; Common Labor / Helper [20 h]; RTR Pipe Crew [52 h]; Driver - Water Tanker [26 h]; Water Tanker [28 h] | 13,338.67 | 1.3.3.40 | CONS | CONS | ZONE-3 | MECH | SEWER |  |
|  | 23 | **Gravity Line From 26A-RA TO 26-RA (200mm upvc) = 36 Lm (Road Crossing)** |  | 2017-06-21 | 2017-06-24 |  |  |  |  |  |  |  |  |  |  |  |  |
| CON-Z3-UT-GRV-PL-600 |  | Remaining Work for Construction of Gravity Line From 26A-RA TO 26-RA (200mm upvc) | 1.6d | 2017-06-21 | 2017-06-22 | CON-Z3-UT-GRV-PL-580 | 45.4d | 0d | Plumber [52 h]; Common Labor / Helper [32 h]; Operator - Loader [26 h]; Driver - Dump Truck [26 h]; Operator - Bobcat [26 h]; Operator - Roller-Compactor (2~10 Ton) [26 h]; Operator - JCB [26 h]; Loader [28 h]; Dump Truck [28 h]; Bobcat [28 h]; Roller-Compactor (2~10 Ton) [28 h]; Plate Compactor [28 h]; Vibrators [28 h]; Water Tanker [28 h]; Air-Compressor 300/900 CFM + Hummer [28 h]; Tower Light [28 h]; Boom Truck (15 Ton) [28 h]; JCB [28 h] | 20,008.01 | 1.3.3.40 | CONS | CONS | ZONE-3 | MECH | SEWER |  |
| CON-Z3-UT-GRV-PL-610 |  | Testing and Precommissioning | 1d | 2017-06-22 | 2017-06-24 | CON-Z3-UT-GRV-PL-600, CON-Z3-UT-GRV-PL-590 SS | 46d | 0.6d | Plumber [52 h]; Common Labor / Helper [52 h]; RTR Pipe Crew [52 h]; Driver - Water Tanker [26 h]; Water Tanker [28 h] | 13,338.67 | 1.3.3.40 | CONS | CONS | ZONE-3 | MECH | SEWER |  |
|  | 24 | **Gravity Line From 31A-RA TO 31-RA (200mm upvc) = 36 Lm (Road Crossing)** |  | 2017-06-22 | 2017-07-01 |  |  |  |  |  |  |  |  |  |  |  |  |
| CON-Z3-UT-GRV-PL-620 |  | Remaining Work for Construction of Gravity Line From 31A-RA TO 31-RA (200mm upvc) | 1.6d | 2017-06-22 | 2017-06-25 | CON-Z3-UT-GRV-PL-600 | 45.4d | 0d | Plumber [52 h]; Common Labor / Helper [104 h]; Operator - Loader [26 h]; Driver - Dump Truck [26 h]; Operator - Bobcat [26 h]; Operator - Roller-Compactor (2~10 Ton) [26 h]; Operator - JCB [26 h]; Loader [28 h]; Dump Truck [28 h]; Bobcat [28 h]; Roller-Compactor (2~10 Ton) [28 h]; Plate Compactor [28 h]; Vibrators [28 h]; Water Tanker [28 h]; Air-Compressor 300/900 CFM + Hummer [28 h]; Tower Light [28 h]; Boom Truck (15 Ton) [28 h]; JCB [28 h] | 20,008.01 | 1.3.3.40 | CONS | CONS | ZONE-3 | MECH | SEWER |  |
| CON-Z3-UT-GRV-PL-630 |  | Testing and Precommissioning | 1d | 2017-06-25 | 2017-07-01 | CON-Z3-UT-GRV-PL-610, CON-Z3-UT-GRV-PL-620 | 45.4d | 12.8d | RTR Pipe Crew [52 h]; Driver - Water Tanker [26 h]; Water Tanker [28 h]; Plumber [52 h]; Common Labor / Helper [52 h] | 13,338.67 | 1.3.3.40 | CONS | CONS | ZONE-3 | MECH | SEWER |  |
|  | 2 | **Sewer Manholes** |  | 2016-11-28 | 2017-04-29 |  |  |  |  |  |  |  |  |  |  |  |  |
|  | 5 | **Sewer Manholes on Road 3 (From SMH-01-R3 To SMH-19-R3) - 19 No.** |  | 2016-11-28 | 2017-03-25 |  |  |  |  |  |  |  |  |  |  |  |  |
| CON-Z3-UT-SEW-MH-010 |  | Cleaning of Manhole | 12d | 2016-11-28 | 2016-12-11 | CON-Z3-UT-GRV-PL-150 | 159.2d | 0d | Common Labor / Helper [60 h] | 14,291.44 | 1.3.3.40 | CONS | CONS | ZONE-3 | MECH | SEWER | ROAD-3 |
| CON-Z3-UT-SEW-MH-020 |  | Benching | 12d | 2016-11-30 | 2016-12-14 | CON-Z3-UT-SEW-MH-010 SS+2.4d | 172.8d | 0d | Concrete Mason [52 h]; Common Labor / Helper [26 h]; Plaster Mason [78 h]; Driver - Conc. Transit Mixers [26 h]; Operator - Concrete Pump [26 h]; Concrete Transit Mixers [28 h]; Concrete Pump [28 h]; Tower Light [28 h] | 21,437.16 | 1.3.3.40 | CONS | CONS | ZONE-3 | MECH | SEWER | ROAD-3 |
| CON-Z3-UT-SEW-MH-030 |  | Internal Finishing | 12d | 2016-12-03 | 2016-12-17 | CON-Z3-UT-SEW-MH-020 SS+2.4d | 172.8d | 54.6d | Concrete Mason [780 h]; Common Labor / Helper [312 h] | 14,291.44 | 1.3.3.40 | CONS | CONS | ZONE-3 | MECH | SEWER | ROAD-3 |
| CON-Z3-UT-SEW-MH-040 |  | Internal Bitumen Coating | 12d | 2017-02-19 | 2017-03-05 | CON-Z3-UT-SEW-MH-030, PR-Z3-CW-CW-23-0080 SS+3d | 118.2d | 0d | Water Proofing Crew [52 h] | 21,437.16 | 1.3.3.40 | CONS | CONS | ZONE-3 | MECH | SEWER | ROAD-3 |
| CON-Z3-UT-SEW-MH-050 |  | Remaining Backfilling | 24d | 2017-02-21 | 2017-03-21 | CON-Z3-UT-SEW-MH-040 SS+2.4d | 118.2d | 0d | Common Labor / Helper [52 h]; Driver - Dump Truck [26 h]; Operator - Bobcat [26 h]; Operator - Roller-Compactor (2~10 Ton) [26 h]; Driver - Water Tanker [26 h]; Operator - JCB [26 h]; Bobcat [28 h]; Plate Compactor [28 h]; Vibrators [28 h]; Water Tanker [28 h]; JCB [28 h] | 28,582.87 | 1.3.3.40 | CONS | CONS | ZONE-3 | MECH | SEWER | ROAD-3 |
| CON-Z3-UT-SEW-MH-060 |  | Construction of Top Concrete Slab | 24d | 2017-02-25 | 2017-03-25 | CON-Z3-UT-SEW-MH-050 SS+2.4d | 118.2d | 0d | Steel Fixer [52 h]; Shuttering Carpenter [52 h]; Concrete Mason [52 h]; Common Labor / Helper [52 h]; Driver - Conc. Transit Mixers [26 h]; Operator - Concrete Pump [26 h]; Concrete Transit Mixers [28 h]; Concrete Pump [28 h] | 28,582.87 | 1.3.3.40 | CONS | CONS | ZONE-3 | MECH | SEWER | ROAD-3 |
| CON-Z3-UT-SEW-MH-070 |  | Installation of D.I Frame and Cover | 12d | 2017-02-27 | 2017-03-13 | CON-Z3-UT-SEW-MH-060 SS+2.4d | 118.2d | 0d | Shuttering Carpenter [26 h]; Concrete Mason [26 h]; Common Labor / Helper [52 h] | 14,291.44 | 1.3.3.40 | CONS | CONS | ZONE-3 | MECH | SEWER | ROAD-3 |

Notes:
- CON-Z3-UT-GRV-PL-550: Expenses: (New Expense Item) 46685.4
- CON-Z3-UT-GRV-PL-540: Expenses: (New Expense Item) 70028
- CON-Z3-UT-GRV-PL-560: Expenses: (New Expense Item) 20008
- CON-Z3-UT-GRV-PL-570: Expenses: (New Expense Item) 13338.7
- CON-Z3-UT-GRV-PL-580: Expenses: (New Expense Item) 20008
- CON-Z3-UT-GRV-PL-590: Expenses: (New Expense Item) 13338.7
- CON-Z3-UT-GRV-PL-600: Expenses: (New Expense Item) 20008
- CON-Z3-UT-GRV-PL-610: Expenses: (New Expense Item) 13338.7
- CON-Z3-UT-GRV-PL-620: Expenses: (New Expense Item) 20008
- CON-Z3-UT-GRV-PL-630: Expenses: (New Expense Item) 13338.7
- CON-Z3-UT-SEW-MH-010: Expenses: (New Expense Item) 14291.4
- CON-Z3-UT-SEW-MH-020: Expenses: (New Expense Item) 21437.2
- CON-Z3-UT-SEW-MH-030: Expenses: (New Expense Item) 14291.4
- CON-Z3-UT-SEW-MH-040: Expenses: (New Expense Item) 21437.2
- CON-Z3-UT-SEW-MH-050: Expenses: (New Expense Item) 28582.9
- CON-Z3-UT-SEW-MH-060: Expenses: (New Expense Item) 28582.9
- CON-Z3-UT-SEW-MH-070: Expenses: (New Expense Item) 14291.4

| ID | WBS | Activity | Duration | Start | Finish | Predecessors | Total float | Free float | Resources | Cost | RPI_P2 - BOQ ITEMS | RPI_P2 - CONSTRUCTION | RPI_P2 - PHASE | RPI_P2 - ZONES | RPI_P2 - AREAS | RPI_P2 - DISCIPLINE / WORK TYPE | RPI_P2 - UTILITY NETWORK |
| --- | --- | --- | --- | --- | --- | --- | --- | --- | --- | --- | --- | --- | --- | --- | --- | --- | --- |
|  | 6 | **Sewer Manholes on Road 2 (From SMH-01-R2 To SMH-18-R2) - 20 No.** |  | 2016-12-12 | 2017-03-27 |  |  |  |  |  |  |  |  |  |  |  |  |
| CON-Z3-UT-SEW-MH-080 |  | Cleaning of Manhole | 12d | 2016-12-12 | 2016-12-25 | CON-Z3-UT-SEW-MH-010 | 159.2d | 0d | Common Labor / Helper [468 h] | 14,291.44 | 1.3.3.40 | CONS | CONS | ZONE-3 | ROAD-2 | MECH | SEWER |
| CON-Z3-UT-SEW-MH-090 |  | Benching | 12d | 2016-12-14 | 2016-12-28 | CON-Z3-UT-SEW-MH-080 SS+2.4d | 182.4d | 0d | Concrete Mason [52 h]; Common Labor / Helper [26 h]; Plaster Mason [78 h]; Driver - Conc. Transit Mixers [26 h]; Operator - Concrete Pump [26 h]; Concrete Transit Mixers [28 h]; Concrete Pump [28 h]; Tower Light [28 h] | 21,437.16 | 1.3.3.40 | CONS | CONS | ZONE-3 | ROAD-2 | MECH | SEWER |
| CON-Z3-UT-SEW-MH-100 |  | Internal Finishing | 12d | 2016-12-17 | 2016-12-31 | CON-Z3-UT-SEW-MH-090 SS+2.4d | 182.4d | 0d | Common Labor / Helper [52 h]; Finishing Work Crew [52 h] | 14,291.44 | 1.3.3.40 | CONS | CONS | ZONE-3 | ROAD-2 | MECH | SEWER |
| CON-Z3-UT-SEW-MH-110 |  | Internal Bitumen Coating | 12d | 2016-12-20 | 2017-01-03 | CON-Z3-UT-SEW-MH-100 SS+2.4d | 182.4d | 0d | Water Proofing Crew [52 h] | 21,437.16 | 1.3.3.40 | CONS | CONS | ZONE-3 | ROAD-2 | MECH | SEWER |
| CON-Z3-UT-SEW-MH-120 |  | Remaining Backfilling | 24d | 2016-12-22 | 2017-01-19 | CON-Z3-UT-SEW-MH-110 SS+2.4d | 182.4d | 0d | Common Labor / Helper [52 h]; Driver - Dump Truck [26 h]; Operator - Bobcat [26 h]; Operator - Roller-Compactor (2~10 Ton) [26 h]; Driver - Water Tanker [26 h]; Operator - JCB [26 h]; Bobcat [28 h]; Plate Compactor [28 h]; Vibrators [28 h]; Water Tanker [28 h]; JCB [28 h] | 28,582.87 | 1.3.3.40 | CONS | CONS | ZONE-3 | ROAD-2 | MECH | SEWER |
| CON-Z3-UT-SEW-MH-130 |  | Construction of Top Concrete Slab | 24d | 2016-12-26 | 2017-01-22 | CON-Z3-UT-SEW-MH-120 SS+2.4d | 182.4d | 64.2d | Steel Fixer [52 h]; Shuttering Carpenter [52 h]; Concrete Mason [52 h]; Common Labor / Helper [52 h]; Driver - Conc. Transit Mixers [26 h]; Operator - Concrete Pump [26 h]; Concrete Transit Mixers [28 h]; Concrete Pump [28 h] | 28,582.87 | 1.3.3.40 | CONS | CONS | ZONE-3 | ROAD-2 | MECH | SEWER |
| CON-Z3-UT-SEW-MH-140 |  | Installation of D.I Frame and Cover | 12d | 2017-03-13 | 2017-03-27 | CON-Z3-UT-SEW-MH-070, CON-Z3-UT-SEW-MH-130 SS+2.4d | 118.2d | 0d | Shuttering Carpenter [120 h]; Concrete Mason [26 h]; Common Labor / Helper [52 h]; Plumber [600 h] | 14,291.44 | 1.3.3.40 | CONS | CONS | ZONE-3 | ROAD-2 | MECH | SEWER |
|  | 1 | **Sewer Manholes on Road 4 (From SMH-01-R4 To SMH-10-R4) - 11 No.** |  | 2016-12-26 | 2017-03-25 |  |  |  |  |  |  |  |  |  |  |  |  |
| CON-Z3-UT-SEW-MH-150 |  | Cleaning of Manhole | 8d | 2016-12-26 | 2017-01-03 | CON-Z3-UT-SEW-MH-080 | 159.2d | 0d | Common Labor / Helper [312 h] | 7,145.72 | 1.3.3.40 | CONS | CONS | ZONE-3 | ROAD-4 | MECH | SEWER |
| CON-Z3-UT-SEW-MH-160 |  | Benching | 8d | 2016-12-28 | 2017-01-07 | CON-Z3-UT-SEW-MH-150 SS+2.4d | 159.2d | 0d | Concrete Mason [52 h]; Common Labor / Helper [26 h]; Plaster Mason [78 h]; Driver - Conc. Transit Mixers [26 h]; Operator - Concrete Pump [26 h]; Concrete Transit Mixers [28 h]; Concrete Pump [28 h]; Tower Light [28 h] | 10,718.58 | 1.3.3.40 | CONS | CONS | ZONE-3 | ROAD-4 | MECH | SEWER |
| CON-Z3-UT-SEW-MH-170 |  | Internal Finishing | 8d | 2016-12-31 | 2017-01-09 | CON-Z3-UT-SEW-MH-160 SS+2.4d | 159.2d | 0d | Common Labor / Helper [52 h]; Finishing Work Crew [52 h] | 7,145.72 | 1.3.3.40 | CONS | CONS | ZONE-3 | ROAD-4 | MECH | SEWER |
| CON-Z3-UT-SEW-MH-180 |  | Internal Bitumen Coating | 8d | 2017-01-03 | 2017-01-12 | CON-Z3-UT-SEW-MH-170 SS+2.4d | 159.2d | 0d | Water Proofing Crew [52 h] | 10,718.58 | 1.3.3.40 | CONS | CONS | ZONE-3 | ROAD-4 | MECH | SEWER |
| CON-Z3-UT-SEW-MH-190 |  | Remaining Backfilling | 16d | 2017-01-05 | 2017-01-24 | CON-Z3-UT-SEW-MH-180 SS+2.4d | 159.2d | 0d | Common Labor / Helper [52 h]; Driver - Dump Truck [26 h]; Operator - Bobcat [26 h]; Operator - Roller-Compactor (2~10 Ton) [26 h]; Driver - Water Tanker [26 h]; Operator - JCB [26 h]; Bobcat [28 h]; Plate Compactor [28 h]; Vibrators [28 h]; Water Tanker [28 h]; JCB [28 h] | 14,291.44 | 1.3.3.40 | CONS | CONS | ZONE-3 | ROAD-4 | MECH | SEWER |
| CON-Z3-UT-SEW-MH-200 |  | Construction of Top Concrete Slab | 16d | 2017-01-09 | 2017-01-26 | CON-Z3-UT-SEW-MH-190 SS+2.4d | 159.2d | 41d | Steel Fixer [52 h]; Shuttering Carpenter [52 h]; Concrete Mason [52 h]; Common Labor / Helper [52 h]; Driver - Conc. Transit Mixers [26 h]; Operator - Concrete Pump [26 h]; Concrete Transit Mixers [28 h]; Concrete Pump [28 h] | 14,291.44 | 1.3.3.40 | CONS | CONS | ZONE-3 | ROAD-4 | MECH | SEWER |
| CON-Z3-UT-SEW-MH-210 |  | Installation of D.I Frame and Cover | 8d | 2017-03-16 | 2017-03-25 | CON-Z3-UT-SEW-MH-200, CON-Z3-UT-SEW-MH-140 SS+2.4d | 118.2d | 0d | Shuttering Carpenter [26 h]; Concrete Mason [26 h]; Common Labor / Helper [52 h] | 7,145.72 | 1.3.3.40 | CONS | CONS | ZONE-3 | ROAD-4 | MECH | SEWER |
|  | 2 | **Sewer Manholes on Road A (From SMH-01-RA To SMH-08-RA & From SMH-26A-RA To SMH-31A-RA) - 17 No** |  | 2016-12-26 | 2017-04-10 |  |  |  |  |  |  |  |  |  |  |  |  |
| CON-Z3-UT-SEW-MH-220 |  | Cleaning of Manhole | 13.6d | 2016-12-26 | 2017-01-10 | CON-Z3-UT-SEW-MH-150 SS | 180.8d | 0d | Common Labor / Helper [530.4 h] | 14,291.44 | 1.3.3.40 | CONS | CONS | ZONE-3 | ROAD-A | MECH | SEWER |
| CON-Z3-UT-SEW-MH-230 |  | Benching | 13.6d | 2016-12-28 | 2017-01-12 | CON-Z3-UT-SEW-MH-220 SS+2.4d | 180.8d | 0d | Concrete Mason [52 h]; Common Labor / Helper [26 h]; Plaster Mason [78 h]; Driver - Conc. Transit Mixers [26 h]; Operator - Concrete Pump [26 h]; Concrete Transit Mixers [28 h]; Concrete Pump [28 h]; Tower Light [28 h] | 21,437.16 | 1.3.3.40 | CONS | CONS | ZONE-3 | ROAD-A | MECH | SEWER |
| CON-Z3-UT-SEW-MH-240 |  | Internal Finishing | 13.6d | 2016-12-31 | 2017-01-16 | CON-Z3-UT-SEW-MH-230 SS+2.4d | 180.8d | 0d | Common Labor / Helper [52 h]; Finishing Work Crew [52 h] | 14,291.44 | 1.3.3.40 | CONS | CONS | ZONE-3 | ROAD-A | MECH | SEWER |
| CON-Z3-UT-SEW-MH-250 |  | Internal Bitumen Coating | 13.6d | 2017-01-03 | 2017-01-18 | CON-Z3-UT-SEW-MH-240 SS+2.4d | 180.8d | 0d | Water Proofing Crew [52 h] | 21,437.16 | 1.3.3.40 | CONS | CONS | ZONE-3 | ROAD-A | MECH | SEWER |
| CON-Z3-UT-SEW-MH-260 |  | Remaining Backfilling | 28d | 2017-01-05 | 2017-02-07 | CON-Z3-UT-SEW-MH-250 SS+2.4d | 180.8d | 0d | Common Labor / Helper [52 h]; Driver - Dump Truck [26 h]; Operator - Bobcat [26 h]; Operator - Roller-Compactor (2~10 Ton) [26 h]; Driver - Water Tanker [26 h]; Operator - JCB [26 h]; Bobcat [28 h]; Plate Compactor [28 h]; Vibrators [28 h]; Water Tanker [28 h]; JCB [28 h] | 28,582.87 | 1.3.3.40 | CONS | CONS | ZONE-3 | ROAD-A | MECH | SEWER |
| CON-Z3-UT-SEW-MH-270 |  | Construction of Top Concrete Slab | 28d | 2017-01-09 | 2017-02-09 | CON-Z3-UT-SEW-MH-260 SS+2.4d | 180.8d | 62.6d | Steel Fixer [52 h]; Shuttering Carpenter [52 h]; Concrete Mason [52 h]; Common Labor / Helper [52 h]; Driver - Conc. Transit Mixers [26 h]; Operator - Concrete Pump [26 h]; Concrete Transit Mixers [28 h]; Concrete Pump [28 h] | 28,582.87 | 1.3.3.40 | CONS | CONS | ZONE-3 | ROAD-A | MECH | SEWER |
| CON-Z3-UT-SEW-MH-280 |  | Installation of D.I Frame and Cover | 13.6d | 2017-03-26 | 2017-04-10 | CON-Z3-UT-SEW-MH-210, CON-Z3-UT-SEW-MH-270 SS+2.4d | 118.2d | 0d | Shuttering Carpenter [26 h]; Concrete Mason [26 h]; Common Labor / Helper [52 h] | 14,291.44 | 1.3.3.40 | CONS | CONS | ZONE-3 | ROAD-A | MECH | SEWER |

Notes:
- CON-Z3-UT-SEW-MH-080: Expenses: (New Expense Item) 14291.4
- CON-Z3-UT-SEW-MH-090: Expenses: (New Expense Item) 21437.2
- CON-Z3-UT-SEW-MH-100: Expenses: (New Expense Item) 14291.4
- CON-Z3-UT-SEW-MH-110: Expenses: (New Expense Item) 21437.2
- CON-Z3-UT-SEW-MH-120: Expenses: (New Expense Item) 28582.9
- CON-Z3-UT-SEW-MH-130: Expenses: (New Expense Item) 28582.9
- CON-Z3-UT-SEW-MH-140: Expenses: (New Expense Item) 14291.4
- CON-Z3-UT-SEW-MH-150: Expenses: (New Expense Item) 7145.72
- CON-Z3-UT-SEW-MH-160: Expenses: (New Expense Item) 10718.6
- CON-Z3-UT-SEW-MH-170: Expenses: (New Expense Item) 7145.72
- CON-Z3-UT-SEW-MH-180: Expenses: (New Expense Item) 10718.6
- CON-Z3-UT-SEW-MH-190: Expenses: (New Expense Item) 14291.4
- CON-Z3-UT-SEW-MH-200: Expenses: (New Expense Item) 14291.4
- CON-Z3-UT-SEW-MH-210: Expenses: (New Expense Item) 7145.72
- CON-Z3-UT-SEW-MH-220: Expenses: (New Expense Item) 14291.4
- CON-Z3-UT-SEW-MH-230: Expenses: (New Expense Item) 21437.2
- CON-Z3-UT-SEW-MH-240: Expenses: (New Expense Item) 14291.4
- CON-Z3-UT-SEW-MH-250: Expenses: (New Expense Item) 21437.2
- CON-Z3-UT-SEW-MH-260: Expenses: (New Expense Item) 28582.9
- CON-Z3-UT-SEW-MH-270: Expenses: (New Expense Item) 28582.9
- CON-Z3-UT-SEW-MH-280: Expenses: (New Expense Item) 14291.4

| ID | WBS | Activity | Duration | Start | Finish | Predecessors | Total float | Free float | Resources | Cost | RPI_P2 - BOQ ITEMS | RPI_P2 - CONSTRUCTION | RPI_P2 - PHASE | RPI_P2 - ZONES | RPI_P2 - AREAS | RPI_P2 - DISCIPLINE / WORK TYPE | RPI_P2 - UTILITY NETWORK |
| --- | --- | --- | --- | --- | --- | --- | --- | --- | --- | --- | --- | --- | --- | --- | --- | --- | --- |
|  | 3 | **Sewer Manholes on Public Realms** |  | 2016-12-28 | 2017-04-29 |  |  |  |  |  |  |  |  |  |  |  |  |
| CON-Z3-UT-SEW-MH-290 |  | Cleaning of Manhole | 16d | 2016-12-28 | 2017-01-16 | CON-Z3-UT-SEW-MH-220 SS+2.4d | 192d | 0d | Common Labor / Helper [624 h] | 21,437.16 | 1.3.3.40 | CONS | CONS | ZONE-3 | REALM | MECH | SEWER |
| CON-Z3-UT-SEW-MH-300 |  | Benching | 16d | 2016-12-31 | 2017-01-18 | CON-Z3-UT-SEW-MH-290 SS+2.4d | 192d | 0d | Concrete Mason [52 h]; Common Labor / Helper [26 h]; Plaster Mason [78 h]; Driver - Conc. Transit Mixers [26 h]; Operator - Concrete Pump [26 h]; Concrete Transit Mixers [28 h]; Concrete Pump [28 h]; Tower Light [28 h] | 32,155.73 | 1.3.3.40 | CONS | CONS | ZONE-3 | REALM | MECH | SEWER |
| CON-Z3-UT-SEW-MH-310 |  | Internal Finishing | 16d | 2017-01-03 | 2017-01-22 | CON-Z3-UT-SEW-MH-300 SS+2.4d | 192d | 0d | Common Labor / Helper [52 h]; Finishing Work Crew [52 h] | 21,437.16 | 1.3.3.40 | CONS | CONS | ZONE-3 | REALM | MECH | SEWER |
| CON-Z3-UT-SEW-MH-320 |  | Internal Bitumen Coating | 16d | 2017-01-05 | 2017-01-24 | CON-Z3-UT-SEW-MH-310 SS+2.4d | 192d | 0d | Water Proofing Crew [52 h] | 32,155.73 | 1.3.3.40 | CONS | CONS | ZONE-3 | REALM | MECH | SEWER |
| CON-Z3-UT-SEW-MH-330 |  | Remaining Backfilling | 32d | 2017-01-09 | 2017-02-14 | CON-Z3-UT-SEW-MH-320 SS+2.4d | 192d | 0d | Common Labor / Helper [52 h]; Driver - Dump Truck [26 h]; Operator - Bobcat [26 h]; Operator - Roller-Compactor (2~10 Ton) [26 h]; Driver - Water Tanker [26 h]; Operator - JCB [26 h]; Bobcat [28 h]; Plate Compactor [28 h]; Vibrators [28 h]; Water Tanker [28 h]; JCB [28 h] | 42,874.31 | 1.3.3.40 | CONS | CONS | ZONE-3 | REALM | MECH | SEWER |
| CON-Z3-UT-SEW-MH-340 |  | Construction of Top Concrete Slab | 32d | 2017-01-11 | 2017-02-18 | CON-Z3-UT-SEW-MH-330 SS+2.4d | 192d | 73.8d | Steel Fixer [52 h]; Shuttering Carpenter [52 h]; Concrete Mason [52 h]; Common Labor / Helper [52 h]; Driver - Conc. Transit Mixers [26 h]; Operator - Concrete Pump [26 h]; Concrete Transit Mixers [28 h]; Concrete Pump [28 h] | 42,874.31 | 1.3.3.40 | CONS | CONS | ZONE-3 | REALM | MECH | SEWER |
| CON-Z3-UT-SEW-MH-350 |  | Installation of D.I Frame and Cover | 16d | 2017-04-10 | 2017-04-29 | CON-Z3-UT-SEW-MH-340 SS+2.4d, CON-Z3-UT-SEW-MH-280 | 118.2d | 15.6d | Shuttering Carpenter [800 h]; Concrete Mason [800 h]; Common Labor / Helper [52 h]; Plumber [480 h] | 21,437.16 | 1.3.3.40 | CONS | CONS | ZONE-3 | REALM | MECH | SEWER |
|  | 2 | **Sewer Force Main System** |  | 2016-12-04 | 2017-07-19 |  |  |  |  |  |  |  |  |  |  |  |  |
|  | 1 | **Force Main Sewer Line** |  | 2016-12-04 | 2017-07-19 |  |  |  |  |  |  |  |  |  |  |  |  |
|  | 3 | **Force Main Line From SLS-10 To Road 5 Crossing (250mm upvc) = 1840 Lm** |  | 2016-12-04 | 2017-07-15 |  |  |  |  |  |  |  |  |  |  |  |  |
| CON-Z3-UT-FM-PL-0130 |  | Excavation of Trench | 15d | 2016-12-04 | 2016-12-21 | CON-Z3-UT-GRV-PL-210 | 48.4d | 0d | Common Labor / Helper [390 h]; Driver - Dump Truck [195 h]; Operator - JCB [195 h]; Dump Truck [210 h]; JCB [210 h] | 128,622.94 | 1.3.3.40 | CONS | CONS | ZONE-3 |  | MECH | SEWER |
| CON-Z3-UT-FM-PL-0140 |  | Compaction and Sand bedding | 10d | 2016-12-08 | 2016-12-19 | CON-Z3-UT-FM-PL-0130 SS+3.2d | 48.4d | 15.8d | Common Labor / Helper [650 h]; Operator - Loader [130 h]; Driver - Dump Truck [130 h]; Operator - JCB [130 h]; Dump Truck [140 h]; JCB [140 h]; Loader [140 h] | 85,748.62 | 1.3.3.40 | CONS | CONS | ZONE-3 |  | MECH | SEWER |
| CON-Z3-UT-FM-PL-0150 |  | Pipe Laying | 45d | 2016-12-29 | 2017-02-20 | PR-Z4-UT-SS-205-0080, CON-Z3-UT-FM-PL-0140 SS+2.4d | 32.6d | 0d | Plumber [3510 h]; Common Labor / Helper [2925 h]; RTR Pipe Crew [1170 h]; Operator - Mobile Crane [585 h]; Driver - Flat Bed Trailer [585 h]; Mobile Crane ( 25-60 Ton) [630 h]; Flat Bed Trailer [630 h] | 214,371.56 | 1.3.3.40 | CONS | CONS | ZONE-3 |  | MECH | SEWER |
| CON-Z3-UT-FM-PL-0160 |  | Installation of Thurst Blcok | 20d | 2017-01-03 | 2017-01-26 | CON-Z3-UT-FM-PL-0150 SS+4d | 53.6d | 21d | Steel Fixer [260 h]; Shuttering Carpenter [260 h]; Concrete Mason [260 h]; Common Labor / Helper [260 h]; Driver - Conc. Transit Mixers [130 h]; Operator - Concrete Pump [130 h]; Concrete Pump [140 h] | 42,874.31 | 1.3.3.40 | CONS | CONS | ZONE-3 |  | MECH | SEWER |
| CON-Z3-UT-FM-PL-0170 |  | Backfilling | 60d | 2017-02-20 | 2017-05-01 | CON-Z3-UT-FM-PL-0160, CON-Z3-UT-FM-PL-0150 | 32.6d | 0d | Common Labor / Helper [3900 h]; Operator - Loader [600 h]; Driver - Dump Truck [600 h]; Operator - Bobcat [600 h]; Operator - Asphalt Compactor / Roller [600 h]; Operator - Roller-Compactor (2~10 Ton) [600 h]; Driver - Water Tanker [600 h]; Operator - JCB [600 h]; Loader [840 h]; Dump Truck [840 h]; Bobcat [840 h]; Roller-Compactor (2~10 Ton) [840 h]; Plate Compactor [840 h]; Vibrators [840 h]; Water Tanker [840 h]; JCB [840 h] | 171,497.25 | 1.3.3.40 | CONS | CONS | ZONE-3 |  | MECH | SEWER |
| CON-Z3-UT-FM-PL-0180 |  | Testing and Precommissioning | 20d | 2017-06-17 | 2017-07-15 | CON-Z3-UT-FM-PL-0170 FS+40d | 32.6d | 0d | Plumber [2000 h]; Common Labor / Helper [2000 h]; RTR Pipe Crew [2000 h]; Driver - Water Tanker [200 h]; Water Tanker [100 h] | 214,371.56 | 1.3.3.40 | CONS | CONS | ZONE-3 |  | MECH | SEWER |
|  | 4 | **Force Main Line From SLS-11 To SMH-01-R7 (250mm upvc) = 200 Lm** |  | 2016-12-21 | 2017-07-19 |  |  |  |  |  |  |  |  |  |  |  |  |
| CON-Z3-UT-FM-PL-0190 |  | Excavation of Trench | 1.6d | 2016-12-21 | 2016-12-24 | CON-Z3-UT-FM-PL-0130 | 184d | 0d | Common Labor / Helper [104 h]; Operator - Excavator [20.8 h]; Driver - Dump Truck [20.8 h]; Excavator [22.4 h]; Dump Truck [22.4 h] | 32,155.73 | 1.3.3.40 | CONS | CONS | ZONE-3 |  | MECH | SEWER |
| CON-Z3-UT-FM-PL-0200 |  | Compaction and Sand bedding | 1.6d | 2016-12-26 | 2016-12-27 | CON-Z3-UT-FM-PL-0190 SS+3.2d | 184d | 0d | Common Labor / Helper [104 h]; Operator - Loader [20.8 h]; Driver - Dump Truck [20.8 h]; Operator - Bobcat [20.8 h]; Operator - JCB [20.8 h]; JCB [22.4 h]; Bobcat [22.4 h]; Loader [22.4 h] | 21,437.16 | 1.3.3.40 | CONS | CONS | ZONE-3 |  | MECH | SEWER |
| CON-Z3-UT-FM-PL-0210 |  | Pipe Laying | 4d | 2016-12-28 | 2017-01-02 | CON-Z3-UT-FM-PL-0200 SS+2.4d | 184d | 0d | Plumber [260 h]; Common Labor / Helper [208 h]; RTR Pipe Crew [104 h]; Operator - Mobile Crane [52 h]; Driver - Flat Bed Trailer [52 h]; Mobile Crane ( 25-60 Ton) [56 h]; Flat Bed Trailer [56 h] | 53,592.89 | 1.3.3.40 | CONS | CONS | ZONE-3 |  | MECH | SEWER |
| CON-Z3-UT-FM-PL-0220 |  | Installation of Thurst Blcok | 2.4d | 2017-01-02 | 2017-01-04 | CON-Z3-UT-FM-PL-0210 SS+4d | 184d | 129.4d | Steel Fixer [26 h]; Shuttering Carpenter [52 h]; Concrete Mason [52 h]; Common Labor / Helper [52 h]; Driver - Conc. Transit Mixers [26 h]; Operator - Concrete Pump [26 h]; Concrete Pump [28 h] | 10,718.58 | 1.3.3.40 | CONS | CONS | ZONE-3 |  | MECH | SEWER |
| CON-Z3-UT-FM-PL-0230 |  | Backfilling | 8d | 2017-06-05 | 2017-06-14 | CON-Z3-UT-FM-PL-0210, CON-Z3-UT-FM-PL-0220, CON-Z3-UT-FM-PL-0170 FS+30d | 54.6d | 22d | Common Labor / Helper [800 h]; Operator - Loader [80 h]; Driver - Dump Truck [80 h]; Operator - Bobcat [80 h]; Operator - Asphalt Compactor / Roller [80 h]; Operator - Roller-Compactor (2~10 Ton) [80 h]; Driver - Water Tanker [80 h]; Operator - JCB [80 h]; Loader [112 h]; Dump Truck [112 h]; Bobcat [112 h]; Roller-Compactor (2~10 Ton) [112 h]; Plate Compactor [336 h]; Vibrators [336 h]; Water Tanker [112 h]; JCB [112 h] | 42,874.31 | 1.3.3.40 | CONS | CONS | ZONE-3 |  | MECH | SEWER |
| CON-Z3-UT-FM-PL-0240 |  | Testing and Precommissioning | 4d | 2017-07-15 | 2017-07-19 | CON-Z3-UT-FM-PL-0230, CON-Z3-UT-FM-PL-0180, CON-Z3-UT-GRV-PL-630 SS | 32.6d | 0d | Plumber [52 h]; Common Labor / Helper [312 h]; RTR Pipe Crew [52 h]; Driver - Water Tanker [52 h]; Water Tanker [56 h] | 53,592.89 | 1.3.3.40 | CONS | CONS | ZONE-3 |  | MECH | SEWER |

Notes:
- CON-Z3-UT-SEW-MH-290: Expenses: (New Expense Item) 21437.2
- CON-Z3-UT-SEW-MH-300: Expenses: (New Expense Item) 32155.7
- CON-Z3-UT-SEW-MH-310: Expenses: (New Expense Item) 21437.2
- CON-Z3-UT-SEW-MH-320: Expenses: (New Expense Item) 32155.7
- CON-Z3-UT-SEW-MH-330: Expenses: (New Expense Item) 42874.3
- CON-Z3-UT-SEW-MH-340: Expenses: (New Expense Item) 42874.3
- CON-Z3-UT-SEW-MH-350: Expenses: (New Expense Item) 21437.2
- CON-Z3-UT-FM-PL-0130: Expenses: (New Expense Item) 128623
- CON-Z3-UT-FM-PL-0140: Expenses: (New Expense Item) 85748.6
- CON-Z3-UT-FM-PL-0150: Expenses: (New Expense Item) 214372
- CON-Z3-UT-FM-PL-0160: Expenses: (New Expense Item) 42874.3
- CON-Z3-UT-FM-PL-0170: Expenses: (New Expense Item) 171497
- CON-Z3-UT-FM-PL-0180: Expenses: (New Expense Item) 214372
- CON-Z3-UT-FM-PL-0190: Expenses: (New Expense Item) 32155.7
- CON-Z3-UT-FM-PL-0200: Expenses: (New Expense Item) 21437.2
- CON-Z3-UT-FM-PL-0210: Expenses: (New Expense Item) 53592.9
- CON-Z3-UT-FM-PL-0220: Expenses: (New Expense Item) 10718.6
- CON-Z3-UT-FM-PL-0230: Expenses: (New Expense Item) 42874.3
- CON-Z3-UT-FM-PL-0240: Expenses: (New Expense Item) 53592.9

| ID | WBS | Activity | Duration | Start | Finish | Predecessors | Total float | Free float | Resources | Cost | Activity Wt% | Weight % | Cost Wt | RPI - PHASE | RPI - CONSTRUCTION | RPI - ZONES | RPI - UTILITY NETWORKS | RPI - TYPE OF WORK | RPI_P2 - BOQ ITEMS | RPI_P2 - CONSTRUCTION | RPI_P2 - PHASE | RPI_P2 - ZONES | RPI_P2 - DISCIPLINE / WORK TYPE | RPI_P2 - UTILITY NETWORK |
| --- | --- | --- | --- | --- | --- | --- | --- | --- | --- | --- | --- | --- | --- | --- | --- | --- | --- | --- | --- | --- | --- | --- | --- | --- |
|  | 3 | **Sanitary Sewer Chambers** |  | 2016-12-21 | 2017-06-06 |  |  |  |  |  |  |  |  |  |  |  |  |  |  |  |  |  |  |  |
|  | 3 | **Slow Down Chamber (SDC-1)** |  | 2016-12-21 | 2017-02-14 |  |  |  |  |  |  |  |  |  |  |  |  |  |  |  |  |  |  |  |
| CON-Z3-UT-SS-VC-0010 |  | Excavation and Compaction | 1.6d | 2016-12-21 | 2016-12-24 | CON-Z3-UT-FM-PL-0130 | 76.2d | 0d | Operator - Excavator [20.8 h]; Excavator [22.4 h]; Common Labor / Helper [62.4 h] | 12,505.01 | 0 | 0 | 0.0030836221 | 6 | RPI - CONS | Z2 | PW | MECH | 1.3.3.40 | CONS | CONS | ZONE-3 | MECH | SEWER |
| CON-Z3-UT-SS-VC-0020 |  | Lean concrete | 0.8d | 2016-12-24 | 2016-12-25 | CON-Z3-UT-SS-VC-0010 | 107.2d | 0d | Concrete Mason [52 h]; Driver - Conc. Transit Mixers [26 h]; Operator - Concrete Pump [26 h] | 7,503 | 0 | 0 | 0.0003088871 | 6 | RPI - CONS | Z2 | PW | MECH | 1.3.3.40 | CONS | CONS | ZONE-3 | MECH | SEWER |
| CON-Z3-UT-SS-VC-0050 |  | Formwork for Base Slab | 0.8d | 2016-12-25 | 2016-12-25 | CON-Z3-UT-SS-VC-0020 | 107.2d | 0d | Shuttering Carpenter [78 h]; Common Labor / Helper [52 h] | 12,505.01 | 0 | 0 | 0.000308358 | 6 | RPI - CONS | Z2 | PW | MECH | 1.3.3.40 | CONS | CONS | ZONE-3 | MECH | SEWER |
| CON-Z3-UT-SS-VC-0030 |  | Fabrication & installation of Rebar for Base Slab | 4d | 2016-12-26 | 2016-12-29 | PR-Z3-CW-CW-25-0080, CON-Z3-UT-SS-VC-0050 | 107.2d | 0d | Steel Fixer [78 h] | 12,505.01 | 0 | 0 | 0.0015418111 | 6 | RPI - CONS | Z2 | PW | MECH | 1.3.3.40 | CONS | CONS | ZONE-3 | MECH | SEWER |
| CON-Z3-UT-SS-VC-0040 |  | Fabrication & installation of Rebar for Side walls | 4d | 2016-12-31 | 2017-01-03 | CON-Z3-UT-SS-VC-0030 | 107.2d | 0d | Steel Fixer [78 h] | 12,505.01 | 0 | 0 | 0.0030836221 | 6 | RPI - CONS | Z2 | PW | MECH | 1.3.3.40 | CONS | CONS | ZONE-3 | MECH | SEWER |
| CON-Z3-UT-SS-VC-0070 |  | Formwork for side walls | 4d | 2016-12-31 | 2017-01-04 | CON-Z3-UT-SS-VC-0040 SS+0.8d | 107.2d | 0d | Shuttering Carpenter [78 h]; Common Labor / Helper [26 h]; Scaffolder [52 h] | 25,010.02 | 0 | 0 | 0.0015418111 | 6 | RPI - CONS | Z2 | PW | MECH | 1.3.3.40 | CONS | CONS | ZONE-3 | MECH | SEWER |
| CON-Z3-UT-SS-VC-0060 |  | Concrete pouring for base slab | 0.8d | 2017-01-04 | 2017-01-05 | CON-Z3-UT-SS-VC-0070 | 107.2d | 0d | Concrete Mason [78 h]; Common Labor / Helper [26 h]; Finishing Work Crew [52 h]; Driver - Conc. Transit Mixers [26 h]; Operator - Concrete Pump [26 h] | 12,505.01 | 0 | 0 | 0.0015418111 | 6 | RPI - CONS | Z2 | PW | MECH | 1.3.3.40 | CONS | CONS | ZONE-3 | MECH | SEWER |
| CON-Z3-UT-SS-VC-0080 |  | Concrete pouring for Side Wall | 0.8d | 2017-01-05 | 2017-01-07 | CON-Z3-UT-SS-VC-0060 | 107.2d | 0d | Concrete Mason [78 h]; Common Labor / Helper [26 h]; Finishing Work Crew [52 h]; Driver - Conc. Transit Mixers [26 h]; Operator - Concrete Pump [26 h] | 25,010.02 | 0 | 0 | 0.0040086961 | 6 | RPI - CONS | Z2 | PW | MECH | 1.3.3.40 | CONS | CONS | ZONE-3 | MECH | SEWER |
| CON-Z3-UT-SS-VC-0090 |  | Formwork removal and concrete patching | 1.6d | 2017-01-07 | 2017-01-08 | CON-Z3-UT-SS-VC-0080 | 107.2d | 0d | Shuttering Carpenter [78 h]; Scaffolder [26 h]; Finishing Work Crew [52 h] | 12,505.01 | 0 | 0 | 0.0015418111 | 6 | RPI - CONS | Z2 | PW | MECH | 1.3.3.40 | CONS | CONS | ZONE-3 | MECH | SEWER |
| CON-Z3-UT-SS-VC-0120 |  | Concrete Supports | 0.8d | 2017-01-09 | 2017-01-09 | CON-Z3-UT-SS-VC-0090 | 107.2d | 9.2d | Shuttering Carpenter [26 h]; Concrete Mason [26 h]; Common Labor / Helper [26 h] | 5,002 | 0 | 0 | 0.000616716 | 6 | RPI - CONS | Z2 | PW | MECH | 1.3.3.40 | CONS | CONS | ZONE-3 | MECH | SEWER |
| CON-Z3-UT-SS-VC-0100 |  | Installation of Valves ,Fittings/ Pipe Connections / Closing of Openings | 6d | 2017-01-21 | 2017-01-26 | CON-Z3-UT-SS-VC-0120, PR-Z3-UT-PW-140-0080, PR-Z3-UT-PW-141-0080 | 98d | 0d | Shuttering Carpenter [26 h]; Concrete Mason [26 h]; Common Labor / Helper [26 h]; RTR Pipe Crew [26 h] | 50,020.03 | 0 | 0 | 0.0055505071 | 6 | RPI - CONS | Z2 | PW | MECH | 1.3.3.40 | CONS | CONS | ZONE-3 | MECH | SEWER |
| CON-Z3-UT-SS-VC-0110 |  | Damp Proof Coating | 0.8d | 2017-01-28 | 2017-01-28 | CON-Z3-UT-SS-VC-0090, CON-Z3-UT-SS-VC-0100 | 98d | 0d | Painter [52 h]; Water Proofing Crew [52 h] | 7,503 | 0 | 0 | 0.0015418111 | 6 | RPI - CONS | Z2 | PW | MECH | 1.3.3.40 | CONS | CONS | ZONE-3 | MECH | SEWER |
| CON-Z3-UT-SS-VC-0130 |  | Backfilling & Compaction | 4d | 2017-01-28 | 2017-02-01 | CON-Z3-UT-SS-VC-0110 | 98d | 0d | Common Labor / Helper [52 h]; Driver - Dump Truck [26 h]; Operator - Bobcat [26 h]; Operator - Roller-Compactor (2~10 Ton) [26 h]; Driver - Water Tanker [26 h]; Operator - JCB [26 h]; Bobcat [28 h]; Plate Compactor [28 h]; Vibrators [28 h]; Water Tanker [28 h]; JCB [28 h] | 25,010.02 | 0 | 0 | 0.0037003381 | 6 | RPI - CONS | Z2 | PW | MECH | 1.3.3.40 | CONS | CONS | ZONE-3 | MECH | SEWER |
| CON-Z3-UT-SS-VC-0140 |  | Installation of Roof Slab, Manhole Cover, Accessories & Finishes | 5.6d | 2017-02-07 | 2017-02-14 | CON-Z3-UT-SS-VC-0130 FS+4.8d | 98d | 18.8d | Common Labor / Helper [436.8 h]; Finishing Work Crew [145.6 h] | 30,012.02 | 0 | 0 | 0.002466885 | 6 | RPI - CONS | Z2 | PW | MECH | 1.3.3.40 | CONS | CONS | ZONE-3 | MECH | SEWER |
|  | 1 | **Air Release Valve Chamber (AV-2)** |  | 2017-01-28 | 2017-03-14 |  |  |  |  |  |  |  |  |  |  |  |  |  |  |  |  |  |  |  |
| CON-Z3-UT-SS-VC-0150 |  | Excavation and Compaction | 1.6d | 2017-01-28 | 2017-01-29 | CON-Z3-UT-SS-VC-0010 FS+30d | 76.2d | 0d | Operator - Excavator [26 h] | 12,505.01 | 0 | 0 | 0.0030836221 | 6 | RPI - CONS | Z2 | PW | MECH | 1.3.3.40 | CONS | CONS | ZONE-3 | MECH | SEWER |
| CON-Z3-UT-SS-VC-0160 |  | Lean concrete | 0.8d | 2017-01-30 | 2017-01-30 | CON-Z3-UT-SS-VC-0150 | 79.2d | 0d | Concrete Mason [52 h]; Driver - Conc. Transit Mixers [26 h]; Operator - Concrete Pump [26 h] | 7,503 | 0 | 0 | 0.0003088871 | 6 | RPI - CONS | Z2 | PW | MECH | 1.3.3.40 | CONS | CONS | ZONE-3 | MECH | SEWER |
| CON-Z3-UT-SS-VC-0190 |  | Formwork for Base Slab | 0.8d | 2017-01-30 | 2017-01-31 | CON-Z3-UT-SS-VC-0160 | 79.2d | 0d | Shuttering Carpenter [78 h]; Common Labor / Helper [52 h] | 12,505.01 | 0 | 0 | 0.000308358 | 6 | RPI - CONS | Z2 | PW | MECH | 1.3.3.40 | CONS | CONS | ZONE-3 | MECH | SEWER |
| CON-Z3-UT-SS-VC-0170 |  | Fabrication & installation of Rebar for Base Slab | 4d | 2017-01-31 | 2017-02-05 | CON-Z3-UT-SS-VC-0190 | 79.2d | 0d | Steel Fixer [78 h] | 12,505.01 | 0 | 0 | 0.0015418111 | 6 | RPI - CONS | Z2 | PW | MECH | 1.3.3.40 | CONS | CONS | ZONE-3 | MECH | SEWER |
| CON-Z3-UT-SS-VC-0180 |  | Fabrication & installation of Rebar for Side walls | 4d | 2017-02-05 | 2017-02-09 | CON-Z3-UT-SS-VC-0170 | 79.2d | 0d | Steel Fixer [208 h]; Common Labor / Helper [156 h] | 12,505.01 | 0 | 0 | 0.0030836221 | 6 | RPI - CONS | Z2 | PW | MECH | 1.3.3.40 | CONS | CONS | ZONE-3 | MECH | SEWER |
| CON-Z3-UT-SS-VC-0210 |  | Formwork for side walls | 4d | 2017-02-06 | 2017-02-11 | CON-Z3-UT-SS-VC-0180 SS+0.8d | 79.2d | 0d | Shuttering Carpenter [260 h]; Common Labor / Helper [208 h]; Scaffolder [156 h] | 25,010.02 | 0 | 0 | 0.0015418111 | 6 | RPI - CONS | Z2 | PW | MECH | 1.3.3.40 | CONS | CONS | ZONE-3 | MECH | SEWER |
| CON-Z3-UT-SS-VC-0200 |  | Concrete pouring for base slab | 0.8d | 2017-02-11 | 2017-02-12 | CON-Z3-UT-SS-VC-0210 | 79.2d | 0d | Concrete Mason [78 h]; Common Labor / Helper [26 h]; Finishing Work Crew [52 h]; Driver - Conc. Transit Mixers [26 h]; Operator - Concrete Pump [26 h] | 12,505.01 | 0 | 0 | 0.0015418111 | 6 | RPI - CONS | Z2 | PW | MECH | 1.3.3.40 | CONS | CONS | ZONE-3 | MECH | SEWER |
| CON-Z3-UT-SS-VC-0220 |  | Concrete pouring for Side Wall | 0.8d | 2017-02-12 | 2017-02-12 | CON-Z3-UT-SS-VC-0200 | 79.2d | 0d | Concrete Mason [78 h]; Common Labor / Helper [26 h]; Finishing Work Crew [52 h]; Driver - Conc. Transit Mixers [26 h]; Operator - Concrete Pump [26 h] | 25,010.02 | 0 | 0 | 0.0040086961 | 6 | RPI - CONS | Z2 | PW | MECH | 1.3.3.40 | CONS | CONS | ZONE-3 | MECH | SEWER |
| CON-Z3-UT-SS-VC-0230 |  | Formwork removal and concrete patching | 1.6d | 2017-02-13 | 2017-02-14 | CON-Z3-UT-SS-VC-0220 | 79.2d | 0d | Shuttering Carpenter [78 h]; Scaffolder [26 h]; Finishing Work Crew [52 h] | 12,505.01 | 0 | 0 | 0.0015418111 | 6 | RPI - CONS | Z2 | PW | MECH | 1.3.3.40 | CONS | CONS | ZONE-3 | MECH | SEWER |
| CON-Z3-UT-SS-VC-0250 |  | Concrete Supports | 0.8d | 2017-02-14 | 2017-02-15 | CON-Z3-UT-SS-VC-0230 | 79.2d | 0d | Shuttering Carpenter [26 h]; Concrete Mason [26 h]; Common Labor / Helper [26 h] | 7,503 | 0 | 0 | 0.000616716 | 6 | RPI - CONS | Z2 | PW | MECH | 1.3.3.40 | CONS | CONS | ZONE-3 | MECH | SEWER |
| CON-Z3-UT-SS-VC-0240 |  | Installation of Valves ,Fittings/ Pipe Connections / Closing of Openings | 8d | 2017-02-15 | 2017-02-25 | CON-Z3-UT-SS-VC-0250, PR-Z3-UT-PW-140-0080, PR-Z3-UT-PW-141-0080 | 79.2d | 0d | Shuttering Carpenter [26 h]; Concrete Mason [26 h]; Common Labor / Helper [26 h]; RTR Pipe Crew [26 h] | 50,020.03 | 0 | 0 | 0.0055505071 | 6 | RPI - CONS | Z2 | PW | MECH | 1.3.3.40 | CONS | CONS | ZONE-3 | MECH | SEWER |
| CON-Z3-UT-SS-VC-0260 |  | Damp Proof Coating | 0.8d | 2017-02-25 | 2017-02-26 | CON-Z3-UT-SS-VC-0240, CON-Z3-UT-SS-VC-0230 | 79.2d | 0d | Painter [52 h]; Water Proofing Crew [52 h] | 5,002 | 0 | 0 | 0.0015418111 | 6 | RPI - CONS | Z2 | PW | MECH | 1.3.3.40 | CONS | CONS | ZONE-3 | MECH | SEWER |
| CON-Z3-UT-SS-VC-0270 |  | Backfilling & Compaction | 4d | 2017-02-26 | 2017-03-02 | CON-Z3-UT-SS-VC-0260 | 79.2d | 0d | Common Labor / Helper [208 h]; Driver - Dump Truck [26 h]; Operator - Bobcat [26 h]; Operator - Roller-Compactor (2~10 Ton) [26 h]; Driver - Water Tanker [26 h]; Operator - JCB [26 h]; Bobcat [28 h]; Plate Compactor [28 h]; Vibrators [28 h]; Water Tanker [28 h]; JCB [28 h] | 25,010.02 | 0 | 0 | 0.0037003381 | 6 | RPI - CONS | Z2 | PW | MECH | 1.3.3.40 | CONS | CONS | ZONE-3 | MECH | SEWER |
| CON-Z3-UT-SS-VC-0280 |  | Installation of Roof Slab, Manhole Cover, Accessories & Finishes | 5.6d | 2017-03-08 | 2017-03-14 | CON-Z3-UT-SS-VC-0270 FS+4.8d, CON-Z3-UT-SS-VC-0140 | 79.2d | 1d | Common Labor / Helper [52 h]; Finishing Work Crew [52 h] | 30,012.02 | 0 | 0 | 0.002466885 | 6 | RPI - CONS | Z2 | PW | MECH | 1.3.3.40 | CONS | CONS | ZONE-3 | MECH | SEWER |

Notes:
- CON-Z3-UT-SS-VC-0010: Expenses: (New Expense Item) 12505
- CON-Z3-UT-SS-VC-0020: Expenses: (New Expense Item) 7503
- CON-Z3-UT-SS-VC-0050: Expenses: (New Expense Item) 12505
- CON-Z3-UT-SS-VC-0030: Expenses: (New Expense Item) 12505
- CON-Z3-UT-SS-VC-0040: Expenses: (New Expense Item) 12505
- CON-Z3-UT-SS-VC-0070: Expenses: (New Expense Item) 25010
- CON-Z3-UT-SS-VC-0060: Expenses: (New Expense Item) 12505
- CON-Z3-UT-SS-VC-0080: Expenses: (New Expense Item) 25010
- CON-Z3-UT-SS-VC-0090: Expenses: (New Expense Item) 12505
- CON-Z3-UT-SS-VC-0120: Expenses: (New Expense Item) 5002
- CON-Z3-UT-SS-VC-0100: Expenses: (New Expense Item) 50020
- CON-Z3-UT-SS-VC-0110: Expenses: (New Expense Item) 7503
- CON-Z3-UT-SS-VC-0130: Expenses: (New Expense Item) 25010
- CON-Z3-UT-SS-VC-0140: Expenses: (New Expense Item) 30012
- CON-Z3-UT-SS-VC-0150: Expenses: (New Expense Item) 12505
- CON-Z3-UT-SS-VC-0160: Expenses: (New Expense Item) 7503
- CON-Z3-UT-SS-VC-0190: Expenses: (New Expense Item) 12505
- CON-Z3-UT-SS-VC-0170: Expenses: (New Expense Item) 12505
- CON-Z3-UT-SS-VC-0180: Expenses: (New Expense Item) 12505
- CON-Z3-UT-SS-VC-0210: Expenses: (New Expense Item) 25010
- CON-Z3-UT-SS-VC-0200: Expenses: (New Expense Item) 12505
- CON-Z3-UT-SS-VC-0220: Expenses: (New Expense Item) 25010
- CON-Z3-UT-SS-VC-0230: Expenses: (New Expense Item) 12505
- CON-Z3-UT-SS-VC-0250: Expenses: (New Expense Item) 7503
- CON-Z3-UT-SS-VC-0240: Expenses: (New Expense Item) 50020
- CON-Z3-UT-SS-VC-0260: Expenses: (New Expense Item) 5002
- CON-Z3-UT-SS-VC-0270: Expenses: (New Expense Item) 25010
- CON-Z3-UT-SS-VC-0280: Expenses: (New Expense Item) 30012

| ID | WBS | Activity | Duration | Start | Finish | Predecessors | Total float | Free float | Resources | Cost | Activity Wt% | Weight % | Cost Wt | RPI - PHASE | RPI - CONSTRUCTION | RPI - ZONES | RPI - UTILITY NETWORKS | RPI - TYPE OF WORK | RPI_P2 - BOQ ITEMS | RPI_P2 - CONSTRUCTION | RPI_P2 - PHASE | RPI_P2 - ZONES | RPI_P2 - DISCIPLINE / WORK TYPE | RPI_P2 - UTILITY NETWORK |
| --- | --- | --- | --- | --- | --- | --- | --- | --- | --- | --- | --- | --- | --- | --- | --- | --- | --- | --- | --- | --- | --- | --- | --- | --- |
|  | 2 | **Washout Valve Chamber (WV-1)** |  | 2017-02-05 | 2017-03-22 |  |  |  |  |  |  |  |  |  |  |  |  |  |  |  |  |  |  |  |
| CON-Z3-UT-SS-VC-0290 |  | Excavation and Compaction | 1.6d | 2017-02-05 | 2017-02-06 | CON-Z3-UT-SS-VC-0150 FS+5d | 76.2d | 0d | Operator - Excavator [20.8 h]; Excavator [22.4 h] | 12,505.01 | 0 | 0 | 0.0030836221 | 6 | RPI - CONS | Z2 | PW | MECH | 1.3.3.40 | CONS | CONS | ZONE-3 | MECH | SEWER |
| CON-Z3-UT-SS-VC-0300 |  | Lean concrete | 0.8d | 2017-02-06 | 2017-02-07 | CON-Z3-UT-SS-VC-0290 | 78.2d | 0d | Concrete Mason [52 h]; Driver - Conc. Transit Mixers [26 h]; Operator - Concrete Pump [26 h] | 7,503 | 0 | 0 | 0.0003088871 | 6 | RPI - CONS | Z2 | PW | MECH | 1.3.3.40 | CONS | CONS | ZONE-3 | MECH | SEWER |
| CON-Z3-UT-SS-VC-0330 |  | Formwork for Base Slab | 0.8d | 2017-02-07 | 2017-02-08 | CON-Z3-UT-SS-VC-0300 | 78.2d | 0d | Shuttering Carpenter [78 h]; Common Labor / Helper [52 h] | 12,505.01 | 0 | 0 | 0.000308358 | 6 | RPI - CONS | Z2 | PW | MECH | 1.3.3.40 | CONS | CONS | ZONE-3 | MECH | SEWER |
| CON-Z3-UT-SS-VC-0310 |  | Fabrication & installation of Rebar for Base Slab | 4d | 2017-02-08 | 2017-02-13 | CON-Z3-UT-SS-VC-0330 | 78.2d | 0d | Steel Fixer [208 h]; Common Labor / Helper [156 h] | 12,505.01 | 0 | 0 | 0.0015418111 | 6 | RPI - CONS | Z2 | PW | MECH | 1.3.3.40 | CONS | CONS | ZONE-3 | MECH | SEWER |
| CON-Z3-UT-SS-VC-0320 |  | Fabrication & installation of Rebar for Side walls | 4d | 2017-02-13 | 2017-02-18 | CON-Z3-UT-SS-VC-0310 | 78.2d | 0d | Steel Fixer [260 h]; Common Labor / Helper [104 h] | 12,505.01 | 0 | 0 | 0.0030836221 | 6 | RPI - CONS | Z2 | PW | MECH | 1.3.3.40 | CONS | CONS | ZONE-3 | MECH | SEWER |
| CON-Z3-UT-SS-VC-0350 |  | Formwork for side walls | 4d | 2017-02-14 | 2017-02-18 | CON-Z3-UT-SS-VC-0320 SS+0.8d | 78.2d | 0d | Shuttering Carpenter [312 h]; Common Labor / Helper [208 h]; Scaffolder [104 h] | 25,010.02 | 0 | 0 | 0.0015418111 | 6 | RPI - CONS | Z2 | PW | MECH | 1.3.3.40 | CONS | CONS | ZONE-3 | MECH | SEWER |
| CON-Z3-UT-SS-VC-0340 |  | Concrete pouring for base slab | 0.8d | 2017-02-19 | 2017-02-19 | CON-Z3-UT-SS-VC-0350 | 78.2d | 0d | Concrete Mason [78 h]; Common Labor / Helper [26 h]; Finishing Work Crew [52 h]; Driver - Conc. Transit Mixers [26 h]; Operator - Concrete Pump [26 h] | 12,505.01 | 0 | 0 | 0.0015418111 | 6 | RPI - CONS | Z2 | PW | MECH | 1.3.3.40 | CONS | CONS | ZONE-3 | MECH | SEWER |
| CON-Z3-UT-SS-VC-0360 |  | Concrete pouring for Side Wall | 0.8d | 2017-02-19 | 2017-02-20 | CON-Z3-UT-SS-VC-0340 | 78.2d | 0d | Concrete Mason [78 h]; Common Labor / Helper [26 h]; Finishing Work Crew [52 h]; Driver - Conc. Transit Mixers [26 h]; Operator - Concrete Pump [26 h] | 25,010.02 | 0 | 0 | 0.0040086961 | 6 | RPI - CONS | Z2 | PW | MECH | 1.3.3.40 | CONS | CONS | ZONE-3 | MECH | SEWER |
| CON-Z3-UT-SS-VC-0370 |  | Formwork removal and concrete patching | 1.6d | 2017-02-20 | 2017-02-22 | CON-Z3-UT-SS-VC-0360 | 78.2d | 0d | Shuttering Carpenter [78 h]; Scaffolder [26 h]; Finishing Work Crew [52 h] | 12,505.01 | 0 | 0 | 0.0015418111 | 6 | RPI - CONS | Z2 | PW | MECH | 1.3.3.40 | CONS | CONS | ZONE-3 | MECH | SEWER |
| CON-Z3-UT-SS-VC-0390 |  | Concrete Supports | 0.8d | 2017-02-22 | 2017-02-22 | CON-Z3-UT-SS-VC-0370 | 78.2d | 0d | Shuttering Carpenter [26 h]; Concrete Mason [26 h]; Common Labor / Helper [26 h] | 7,503 | 0 | 0 | 0.000616716 | 6 | RPI - CONS | Z2 | PW | MECH | 1.3.3.40 | CONS | CONS | ZONE-3 | MECH | SEWER |
| CON-Z3-UT-SS-VC-0380 |  | Installation of Valves ,Fittings/ Pipe Connections / Closing of Openings | 8d | 2017-02-23 | 2017-03-04 | CON-Z3-UT-SS-VC-0390 | 78.2d | 0d | Shuttering Carpenter [416 h]; Concrete Mason [208 h]; Common Labor / Helper [416 h]; RTR Pipe Crew [208 h] | 50,020.03 | 0 | 0 | 0.0055505071 | 6 | RPI - CONS | Z2 | PW | MECH | 1.3.3.40 | CONS | CONS | ZONE-3 | MECH | SEWER |
| CON-Z3-UT-SS-VC-0400 |  | Damp Proof Coating | 0.8d | 2017-03-05 | 2017-03-05 | CON-Z3-UT-SS-VC-0370, CON-Z3-UT-SS-VC-0380 | 78.2d | 0d | Painter [52 h]; Water Proofing Crew [52 h] | 5,002 | 0 | 0 | 0.0015418111 | 6 | RPI - CONS | Z2 | PW | MECH | 1.3.3.40 | CONS | CONS | ZONE-3 | MECH | SEWER |
| CON-Z3-UT-SS-VC-0410 |  | Backfilling & Compaction | 4d | 2017-03-05 | 2017-03-09 | CON-Z3-UT-SS-VC-0400 | 78.2d | 0d | Common Labor / Helper [52 h]; Driver - Dump Truck [26 h]; Operator - Bobcat [26 h]; Operator - Roller-Compactor (2~10 Ton) [26 h]; Driver - Water Tanker [26 h]; Operator - JCB [26 h]; Bobcat [28 h]; Plate Compactor [28 h]; Vibrators [28 h]; Water Tanker [28 h]; JCB [28 h] | 25,010.02 | 0 | 0 | 0.0037003381 | 6 | RPI - CONS | Z2 | PW | MECH | 1.3.3.40 | CONS | CONS | ZONE-3 | MECH | SEWER |
| CON-Z3-UT-SS-VC-0420 |  | Installation of Roof Slab, Manhole Cover, Accessories & Finishes | 5.6d | 2017-03-15 | 2017-03-22 | CON-Z3-UT-SS-VC-0280, CON-Z3-UT-SS-VC-0410 FS+4.8d, CON-Z3-UT-SS-VC-0140 | 78.2d | 1d | Common Labor / Helper [52 h]; Finishing Work Crew [52 h] | 30,012.02 | 0 | 0 | 0.002466885 | 6 | RPI - CONS | Z2 | PW | MECH | 1.3.3.40 | CONS | CONS | ZONE-3 | MECH | SEWER |
|  | 4 | **Air Release Valve Chamber (AV-2A)** |  | 2017-02-12 | 2017-03-29 |  |  |  |  |  |  |  |  |  |  |  |  |  |  |  |  |  |  |  |
| CON-Z3-UT-SS-VC-0430 |  | Excavation and Compaction | 1.6d | 2017-02-12 | 2017-02-14 | CON-Z3-UT-SS-VC-0290 FS+5d | 76.2d | 0d | Operator - Excavator [26 h] | 12,505.01 | 0 | 0 | 0.0030836221 | 6 | RPI - CONS | Z2 | PW | MECH | 1.3.3.40 | CONS | CONS | ZONE-3 | MECH | SEWER |
| CON-Z3-UT-SS-VC-0440 |  | Lean concrete | 0.8d | 2017-02-14 | 2017-02-14 | CON-Z3-UT-SS-VC-0430 | 77.2d | 0d | Concrete Mason [52 h]; Driver - Conc. Transit Mixers [26 h]; Operator - Concrete Pump [26 h] | 7,503 | 0 | 0 | 0.0003088871 | 6 | RPI - CONS | Z2 | PW | MECH | 1.3.3.40 | CONS | CONS | ZONE-3 | MECH | SEWER |
| CON-Z3-UT-SS-VC-0470 |  | Formwork for Base Slab | 0.8d | 2017-02-15 | 2017-02-15 | CON-Z3-UT-SS-VC-0440 | 77.2d | 0d | Shuttering Carpenter [78 h]; Common Labor / Helper [52 h] | 12,505.01 | 0 | 0 | 0.000308358 | 6 | RPI - CONS | Z2 | PW | MECH | 1.3.3.40 | CONS | CONS | ZONE-3 | MECH | SEWER |
| CON-Z3-UT-SS-VC-0450 |  | Fabrication & installation of Rebar for Base Slab | 4d | 2017-02-15 | 2017-02-20 | CON-Z3-UT-SS-VC-0470 | 77.2d | 0d | Steel Fixer [78 h] | 12,505.01 | 0 | 0 | 0.0015418111 | 6 | RPI - CONS | Z2 | PW | MECH | 1.3.3.40 | CONS | CONS | ZONE-3 | MECH | SEWER |
| CON-Z3-UT-SS-VC-0460 |  | Fabrication & installation of Rebar for Side walls | 4d | 2017-02-20 | 2017-02-25 | CON-Z3-UT-SS-VC-0450 | 77.2d | 0d | Steel Fixer [78 h] | 12,505.01 | 0 | 0 | 0.0030836221 | 6 | RPI - CONS | Z2 | PW | MECH | 1.3.3.40 | CONS | CONS | ZONE-3 | MECH | SEWER |
| CON-Z3-UT-SS-VC-0490 |  | Formwork for side walls | 4d | 2017-02-21 | 2017-02-26 | CON-Z3-UT-SS-VC-0460 SS+0.8d | 77.2d | 0d | Shuttering Carpenter [78 h]; Common Labor / Helper [26 h]; Scaffolder [52 h] | 25,010.02 | 0 | 0 | 0.0015418111 | 6 | RPI - CONS | Z2 | PW | MECH | 1.3.3.40 | CONS | CONS | ZONE-3 | MECH | SEWER |
| CON-Z3-UT-SS-VC-0480 |  | Concrete pouring for base slab | 0.8d | 2017-02-26 | 2017-02-27 | CON-Z3-UT-SS-VC-0490 | 77.2d | 0d | Concrete Mason [78 h]; Common Labor / Helper [26 h]; Finishing Work Crew [52 h]; Driver - Conc. Transit Mixers [26 h]; Operator - Concrete Pump [26 h] | 12,505.01 | 0 | 0 | 0.0015418111 | 6 | RPI - CONS | Z2 | PW | MECH | 1.3.3.40 | CONS | CONS | ZONE-3 | MECH | SEWER |
| CON-Z3-UT-SS-VC-0500 |  | Concrete pouring for Side Wall | 0.8d | 2017-02-27 | 2017-02-28 | CON-Z3-UT-SS-VC-0480 | 77.2d | 0d | Concrete Mason [78 h]; Common Labor / Helper [26 h]; Finishing Work Crew [52 h]; Driver - Conc. Transit Mixers [26 h]; Operator - Concrete Pump [26 h] | 25,010.02 | 0 | 0 | 0.0040086961 | 6 | RPI - CONS | Z2 | PW | MECH | 1.3.3.40 | CONS | CONS | ZONE-3 | MECH | SEWER |
| CON-Z3-UT-SS-VC-0510 |  | Formwork removal and concrete patching | 1.6d | 2017-02-28 | 2017-03-01 | CON-Z3-UT-SS-VC-0500 | 77.2d | 0d | Shuttering Carpenter [78 h]; Scaffolder [26 h]; Finishing Work Crew [52 h] | 12,505.01 | 0 | 0 | 0.0015418111 | 6 | RPI - CONS | Z2 | PW | MECH | 1.3.3.40 | CONS | CONS | ZONE-3 | MECH | SEWER |
| CON-Z3-UT-SS-VC-0530 |  | Concrete Supports | 0.8d | 2017-03-01 | 2017-03-02 | CON-Z3-UT-SS-VC-0510 | 77.2d | 0d | Shuttering Carpenter [26 h]; Concrete Mason [26 h]; Common Labor / Helper [26 h] | 7,503 | 0 | 0 | 0.000616716 | 6 | RPI - CONS | Z2 | PW | MECH | 1.3.3.40 | CONS | CONS | ZONE-3 | MECH | SEWER |
| CON-Z3-UT-SS-VC-0520 |  | Installation of Valves ,Fittings/ Pipe Connections / Closing of Openings | 8d | 2017-03-02 | 2017-03-12 | CON-Z3-UT-SS-VC-0530 | 77.2d | 0d | Shuttering Carpenter [26 h]; Concrete Mason [26 h]; Common Labor / Helper [26 h]; RTR Pipe Crew [26 h] | 50,020.03 | 0 | 0 | 0.0055505071 | 6 | RPI - CONS | Z2 | PW | MECH | 1.3.3.40 | CONS | CONS | ZONE-3 | MECH | SEWER |
| CON-Z3-UT-SS-VC-0540 |  | Damp Proof Coating | 0.8d | 2017-03-12 | 2017-03-13 | CON-Z3-UT-SS-VC-0510, CON-Z3-UT-SS-VC-0520 | 77.2d | 0d | Painter [52 h]; Water Proofing Crew [52 h] | 5,002 | 0 | 0 | 0.0015418111 | 6 | RPI - CONS | Z2 | PW | MECH | 1.3.3.40 | CONS | CONS | ZONE-3 | MECH | SEWER |
| CON-Z3-UT-SS-VC-0550 |  | Backfilling & Compaction | 4d | 2017-03-13 | 2017-03-18 | CON-Z3-UT-SS-VC-0540 | 77.2d | 0d | JCB [28 h]; Common Labor / Helper [52 h]; Driver - Dump Truck [26 h]; Operator - Bobcat [26 h]; Operator - Roller-Compactor (2~10 Ton) [26 h]; Driver - Water Tanker [26 h]; Operator - JCB [26 h]; Bobcat [28 h]; Plate Compactor [28 h]; Vibrators [28 h]; Water Tanker [28 h] | 25,010.02 | 0 | 0 | 0.0037003381 | 6 | RPI - CONS | Z2 | PW | MECH | 1.3.3.40 | CONS | CONS | ZONE-3 | MECH | SEWER |
| CON-Z3-UT-SS-VC-0560 |  | Installation of Roof Slab, Manhole Cover, Accessories & Finishes | 5.6d | 2017-03-23 | 2017-03-29 | CON-Z3-UT-SS-VC-0550 FS+4.8d, CON-Z3-UT-SS-VC-0420 | 77.2d | 1d | Common Labor / Helper [52 h]; Finishing Work Crew [52 h] | 30,012.02 | 0 | 0 | 0.002466885 | 6 | RPI - CONS | Z2 | PW | MECH | 1.3.3.40 | CONS | CONS | ZONE-3 | MECH | SEWER |

Notes:
- CON-Z3-UT-SS-VC-0290: Expenses: (New Expense Item) 12505
- CON-Z3-UT-SS-VC-0300: Expenses: (New Expense Item) 7503
- CON-Z3-UT-SS-VC-0330: Expenses: (New Expense Item) 12505
- CON-Z3-UT-SS-VC-0310: Expenses: (New Expense Item) 12505
- CON-Z3-UT-SS-VC-0320: Expenses: (New Expense Item) 12505
- CON-Z3-UT-SS-VC-0350: Expenses: (New Expense Item) 25010
- CON-Z3-UT-SS-VC-0340: Expenses: (New Expense Item) 12505
- CON-Z3-UT-SS-VC-0360: Expenses: (New Expense Item) 25010
- CON-Z3-UT-SS-VC-0370: Expenses: (New Expense Item) 12505
- CON-Z3-UT-SS-VC-0390: Expenses: (New Expense Item) 7503
- CON-Z3-UT-SS-VC-0380: Expenses: (New Expense Item) 50020
- CON-Z3-UT-SS-VC-0400: Expenses: (New Expense Item) 5002
- CON-Z3-UT-SS-VC-0410: Expenses: (New Expense Item) 25010
- CON-Z3-UT-SS-VC-0420: Expenses: (New Expense Item) 30012
- CON-Z3-UT-SS-VC-0430: Expenses: (New Expense Item) 12505
- CON-Z3-UT-SS-VC-0440: Expenses: (New Expense Item) 7503
- CON-Z3-UT-SS-VC-0470: Expenses: (New Expense Item) 12505
- CON-Z3-UT-SS-VC-0450: Expenses: (New Expense Item) 12505
- CON-Z3-UT-SS-VC-0460: Expenses: (New Expense Item) 12505
- CON-Z3-UT-SS-VC-0490: Expenses: (New Expense Item) 25010
- CON-Z3-UT-SS-VC-0480: Expenses: (New Expense Item) 12505
- CON-Z3-UT-SS-VC-0500: Expenses: (New Expense Item) 25010
- CON-Z3-UT-SS-VC-0510: Expenses: (New Expense Item) 12505
- CON-Z3-UT-SS-VC-0530: Expenses: (New Expense Item) 7503
- CON-Z3-UT-SS-VC-0520: Expenses: (New Expense Item) 50020
- CON-Z3-UT-SS-VC-0540: Expenses: (New Expense Item) 5002
- CON-Z3-UT-SS-VC-0550: Expenses: (New Expense Item) 25010
- CON-Z3-UT-SS-VC-0560: Expenses: (New Expense Item) 30012

| ID | WBS | Activity | Duration | Start | Finish | Predecessors | Total float | Free float | Resources | Cost | Activity Wt% | Weight % | Cost Wt | RPI - PHASE | RPI - CONSTRUCTION | RPI - ZONES | RPI - UTILITY NETWORKS | RPI - TYPE OF WORK | RPI_P2 - BOQ ITEMS | RPI_P2 - CONSTRUCTION | RPI_P2 - PHASE | RPI_P2 - ZONES | RPI_P2 - DISCIPLINE / WORK TYPE | RPI_P2 - UTILITY NETWORK |
| --- | --- | --- | --- | --- | --- | --- | --- | --- | --- | --- | --- | --- | --- | --- | --- | --- | --- | --- | --- | --- | --- | --- | --- | --- |
|  | 5 | **Air Release Valve Chamber (AV-3)** |  | 2017-02-20 | 2017-04-06 |  |  |  |  |  |  |  |  |  |  |  |  |  |  |  |  |  |  |  |
| CON-Z3-UT-SS-VC-0570 |  | Excavation and Compaction | 1.6d | 2017-02-20 | 2017-02-21 | CON-Z3-UT-SS-VC-0430 FS+5d | 76.2d | 0d | Operator - Excavator [26 h] | 12,505.01 | 0 | 0 | 0.0030836221 | 6 | RPI - CONS | Z2 | PW | MECH | 1.3.3.40 | CONS | CONS | ZONE-3 | MECH | SEWER |
| CON-Z3-UT-SS-VC-0580 |  | Lean concrete | 0.8d | 2017-02-21 | 2017-02-22 | CON-Z3-UT-SS-VC-0570 | 76.2d | 0d | Concrete Mason [52 h]; Driver - Conc. Transit Mixers [26 h]; Operator - Concrete Pump [26 h] | 7,503 | 0 | 0 | 0.0003088871 | 6 | RPI - CONS | Z2 | PW | MECH | 1.3.3.40 | CONS | CONS | ZONE-3 | MECH | SEWER |
| CON-Z3-UT-SS-VC-0610 |  | Formwork for Base Slab | 0.8d | 2017-02-22 | 2017-02-23 | CON-Z3-UT-SS-VC-0580 | 76.2d | 0d | Shuttering Carpenter [78 h]; Common Labor / Helper [52 h] | 12,505.01 | 0 | 0 | 0.000308358 | 6 | RPI - CONS | Z2 | PW | MECH | 1.3.3.40 | CONS | CONS | ZONE-3 | MECH | SEWER |
| CON-Z3-UT-SS-VC-0590 |  | Fabrication & installation of Rebar for Base Slab | 4d | 2017-02-23 | 2017-02-28 | CON-Z3-UT-SS-VC-0610 | 76.2d | 0d | Steel Fixer [78 h] | 12,505.01 | 0 | 0 | 0.0015418111 | 6 | RPI - CONS | Z2 | PW | MECH | 1.3.3.40 | CONS | CONS | ZONE-3 | MECH | SEWER |
| CON-Z3-UT-SS-VC-0600 |  | Fabrication & installation of Rebar for Side walls | 4d | 2017-02-28 | 2017-03-05 | CON-Z3-UT-SS-VC-0590 | 76.2d | 0d | Steel Fixer [78 h] | 12,505.01 | 0 | 0 | 0.0030836221 | 6 | RPI - CONS | Z2 | PW | MECH | 1.3.3.40 | CONS | CONS | ZONE-3 | MECH | SEWER |
| CON-Z3-UT-SS-VC-0630 |  | Formwork for side walls | 4d | 2017-03-01 | 2017-03-06 | CON-Z3-UT-SS-VC-0600 SS+0.8d | 76.2d | 0d | Shuttering Carpenter [78 h]; Common Labor / Helper [26 h]; Scaffolder [52 h] | 25,010.02 | 0 | 0 | 0.0015418111 | 6 | RPI - CONS | Z2 | PW | MECH | 1.3.3.40 | CONS | CONS | ZONE-3 | MECH | SEWER |
| CON-Z3-UT-SS-VC-0620 |  | Concrete pouring for base slab | 0.8d | 2017-03-06 | 2017-03-06 | CON-Z3-UT-SS-VC-0630 | 76.2d | 0d | Concrete Mason [78 h]; Common Labor / Helper [26 h]; Finishing Work Crew [52 h]; Driver - Conc. Transit Mixers [26 h]; Operator - Concrete Pump [26 h] | 12,505.01 | 0 | 0 | 0.0015418111 | 6 | RPI - CONS | Z2 | PW | MECH | 1.3.3.40 | CONS | CONS | ZONE-3 | MECH | SEWER |
| CON-Z3-UT-SS-VC-0640 |  | Concrete pouring for Side Wall | 0.8d | 2017-03-07 | 2017-03-07 | CON-Z3-UT-SS-VC-0620 | 76.2d | 0d | Concrete Mason [78 h]; Common Labor / Helper [26 h]; Finishing Work Crew [52 h]; Driver - Conc. Transit Mixers [26 h]; Operator - Concrete Pump [26 h] | 25,010.02 | 0 | 0 | 0.0040086961 | 6 | RPI - CONS | Z2 | PW | MECH | 1.3.3.40 | CONS | CONS | ZONE-3 | MECH | SEWER |
| CON-Z3-UT-SS-VC-0650 |  | Formwork removal and concrete patching | 1.6d | 2017-03-07 | 2017-03-09 | CON-Z3-UT-SS-VC-0640 | 76.2d | 0d | Shuttering Carpenter [78 h]; Scaffolder [26 h]; Finishing Work Crew [52 h] | 12,505.01 | 0 | 0 | 0.0015418111 | 6 | RPI - CONS | Z2 | PW | MECH | 1.3.3.40 | CONS | CONS | ZONE-3 | MECH | SEWER |
| CON-Z3-UT-SS-VC-0670 |  | Concrete Supports | 0.8d | 2017-03-09 | 2017-03-11 | CON-Z3-UT-SS-VC-0650 | 76.2d | 0d | Shuttering Carpenter [26 h]; Concrete Mason [26 h]; Common Labor / Helper [26 h] | 7,503 | 0 | 0 | 0.000616716 | 6 | RPI - CONS | Z2 | PW | MECH | 1.3.3.40 | CONS | CONS | ZONE-3 | MECH | SEWER |
| CON-Z3-UT-SS-VC-0660 |  | Installation of Valves ,Fittings/ Pipe Connections / Closing of Openings | 8d | 2017-03-11 | 2017-03-20 | CON-Z3-UT-SS-VC-0670 | 76.2d | 0d | Shuttering Carpenter [26 h]; Concrete Mason [26 h]; Common Labor / Helper [26 h]; RTR Pipe Crew [26 h] | 50,020.03 | 0 | 0 | 0.0055505071 | 6 | RPI - CONS | Z2 | PW | MECH | 1.3.3.40 | CONS | CONS | ZONE-3 | MECH | SEWER |
| CON-Z3-UT-SS-VC-0680 |  | Damp Proof Coating | 0.8d | 2017-03-20 | 2017-03-20 | CON-Z3-UT-SS-VC-0650, CON-Z3-UT-SS-VC-0660 | 76.2d | 0d | Painter [52 h]; Water Proofing Crew [52 h] | 5,002 | 0 | 0 | 0.0015418111 | 6 | RPI - CONS | Z2 | PW | MECH | 1.3.3.40 | CONS | CONS | ZONE-3 | MECH | SEWER |
| CON-Z3-UT-SS-VC-0690 |  | Backfilling & Compaction | 4d | 2017-03-21 | 2017-03-25 | CON-Z3-UT-SS-VC-0680 | 76.2d | 0d | Common Labor / Helper [52 h]; Driver - Dump Truck [26 h]; Operator - Bobcat [26 h]; Operator - Roller-Compactor (2~10 Ton) [26 h]; Driver - Water Tanker [26 h]; Operator - JCB [26 h]; Bobcat [28 h]; Plate Compactor [28 h]; Vibrators [28 h]; Water Tanker [28 h]; JCB [28 h] | 25,010.02 | 0 | 0 | 0.0037003381 | 6 | RPI - CONS | Z2 | PW | MECH | 1.3.3.40 | CONS | CONS | ZONE-3 | MECH | SEWER |
| CON-Z3-UT-SS-VC-0700 |  | Installation of Roof Slab, Manhole Cover, Accessories & Finishes | 5.6d | 2017-03-30 | 2017-04-06 | CON-Z3-UT-SS-VC-0690 FS+4.8d, CON-Z3-UT-SS-VC-0560 | 76.2d | 0d | Common Labor / Helper [52 h]; Finishing Work Crew [52 h] | 30,012.02 | 0 | 0 | 0.002466885 | 6 | RPI - CONS | Z2 | PW | MECH | 1.3.3.40 | CONS | CONS | ZONE-3 | MECH | SEWER |
|  | 6 | **Washout Valve Chamber (WV-2)** |  | 2017-02-27 | 2017-05-17 |  |  |  |  |  |  |  |  |  |  |  |  |  |  |  |  |  |  |  |
| CON-Z3-UT-SS-VC-0710 |  | Excavation and Compaction | 1.6d | 2017-02-27 | 2017-03-01 | CON-Z3-UT-SS-VC-0570 FS+5d | 78.2d | 0d | Operator - Excavator [26 h] | 12,505.01 | 0 | 0 | 0.0030836221 | 6 | RPI - CONS | Z2 | PW | MECH | 1.3.3.40 | CONS | CONS | ZONE-3 | MECH | SEWER |
| CON-Z3-UT-SS-VC-0720 |  | Lean concrete | 0.8d | 2017-03-01 | 2017-03-02 | CON-Z3-UT-SS-VC-0710 | 105.2d | 0d | Concrete Mason [52 h]; Driver - Conc. Transit Mixers [26 h]; Operator - Concrete Pump [26 h] | 7,503 | 0 | 0 | 0.0003088871 | 6 | RPI - CONS | Z2 | PW | MECH | 1.3.3.40 | CONS | CONS | ZONE-3 | MECH | SEWER |
| CON-Z3-UT-SS-VC-0750 |  | Formwork for Base Slab | 0.8d | 2017-03-02 | 2017-03-02 | CON-Z3-UT-SS-VC-0720 | 105.2d | 0d | Shuttering Carpenter [78 h]; Common Labor / Helper [52 h] | 12,505.01 | 0 | 0 | 0.000308358 | 6 | RPI - CONS | Z2 | PW | MECH | 1.3.3.40 | CONS | CONS | ZONE-3 | MECH | SEWER |
| CON-Z3-UT-SS-VC-0730 |  | Fabrication & installation of Rebar for Base Slab | 4d | 2017-03-04 | 2017-03-07 | CON-Z3-UT-SS-VC-0750 | 105.2d | 0d | Steel Fixer [78 h] | 12,505.01 | 0 | 0 | 0.0015418111 | 6 | RPI - CONS | Z2 | PW | MECH | 1.3.3.40 | CONS | CONS | ZONE-3 | MECH | SEWER |
| CON-Z3-UT-SS-VC-0740 |  | Fabrication & installation of Rebar for Side walls | 4d | 2017-03-08 | 2017-03-12 | CON-Z3-UT-SS-VC-0730 | 105.2d | 0d | Steel Fixer [78 h] | 12,505.01 | 0 | 0 | 0.0030836221 | 6 | RPI - CONS | Z2 | PW | MECH | 1.3.3.40 | CONS | CONS | ZONE-3 | MECH | SEWER |
| CON-Z3-UT-SS-VC-0770 |  | Formwork for side walls | 4d | 2017-03-08 | 2017-03-13 | CON-Z3-UT-SS-VC-0740 SS+0.8d | 105.2d | 0d | Shuttering Carpenter [78 h]; Common Labor / Helper [26 h]; Scaffolder [52 h] | 25,010.02 | 0 | 0 | 0.0015418111 | 6 | RPI - CONS | Z2 | PW | MECH | 1.3.3.40 | CONS | CONS | ZONE-3 | MECH | SEWER |
| CON-Z3-UT-SS-VC-0760 |  | Concrete pouring for base slab | 0.8d | 2017-03-13 | 2017-03-14 | CON-Z3-UT-SS-VC-0770 | 105.2d | 0d | Concrete Mason [78 h]; Common Labor / Helper [26 h]; Finishing Work Crew [52 h]; Driver - Conc. Transit Mixers [26 h]; Operator - Concrete Pump [26 h] | 12,505.01 | 0 | 0 | 0.0015418111 | 6 | RPI - CONS | Z2 | PW | MECH | 1.3.3.40 | CONS | CONS | ZONE-3 | MECH | SEWER |
| CON-Z3-UT-SS-VC-0780 |  | Concrete pouring for Side Wall | 0.8d | 2017-03-14 | 2017-03-15 | CON-Z3-UT-SS-VC-0760 | 105.2d | 0d | Concrete Mason [78 h]; Common Labor / Helper [26 h]; Finishing Work Crew [52 h]; Driver - Conc. Transit Mixers [26 h]; Operator - Concrete Pump [26 h] | 25,010.02 | 0 | 0 | 0.0040086961 | 6 | RPI - CONS | Z2 | PW | MECH | 1.3.3.40 | CONS | CONS | ZONE-3 | MECH | SEWER |
| CON-Z3-UT-SS-VC-0790 |  | Formwork removal and concrete patching | 1.6d | 2017-03-15 | 2017-03-16 | CON-Z3-UT-SS-VC-0780 | 105.2d | 0d | Shuttering Carpenter [78 h]; Scaffolder [26 h]; Finishing Work Crew [52 h] | 12,505.01 | 0 | 0 | 0.0015418111 | 6 | RPI - CONS | Z2 | PW | MECH | 1.3.3.40 | CONS | CONS | ZONE-3 | MECH | SEWER |
| CON-Z3-UT-SS-VC-0810 |  | Concrete Supports | 0.8d | 2017-03-18 | 2017-03-18 | CON-Z3-UT-SS-VC-0790 | 105.2d | 0d | Shuttering Carpenter [26 h]; Concrete Mason [26 h]; Common Labor / Helper [26 h] | 7,503 | 0 | 0 | 0.000616716 | 6 | RPI - CONS | Z2 | PW | MECH | 1.3.3.40 | CONS | CONS | ZONE-3 | MECH | SEWER |
| CON-Z3-UT-SS-VC-0800 |  | Installation of Valves ,Fittings/ Pipe Connections / Closing of Openings | 8d | 2017-03-18 | 2017-03-27 | CON-Z3-UT-SS-VC-0810 | 105.2d | 0d | Shuttering Carpenter [26 h]; Concrete Mason [26 h]; Common Labor / Helper [26 h]; RTR Pipe Crew [26 h] | 50,020.03 | 0 | 0 | 0.0055505071 | 6 | RPI - CONS | Z2 | PW | MECH | 1.3.3.40 | CONS | CONS | ZONE-3 | MECH | SEWER |
| CON-Z3-UT-SS-VC-0820 |  | Damp Proof Coating | 0.8d | 2017-03-27 | 2017-03-28 | CON-Z3-UT-SS-VC-0790, CON-Z3-UT-SS-VC-0800 | 105.2d | 0d | Painter [52 h]; Water Proofing Crew [52 h] | 5,002 | 0 | 0 | 0.0015418111 | 6 | RPI - CONS | Z2 | PW | MECH | 1.3.3.40 | CONS | CONS | ZONE-3 | MECH | SEWER |
| CON-Z3-UT-SS-VC-0830 |  | Backfilling & Compaction | 4d | 2017-03-28 | 2017-04-02 | CON-Z3-UT-SS-VC-0820 | 105.2d | 29d | Common Labor / Helper [52 h]; Driver - Dump Truck [26 h]; Operator - Bobcat [26 h]; Operator - Roller-Compactor (2~10 Ton) [26 h]; Driver - Water Tanker [26 h]; Operator - JCB [26 h]; Bobcat [28 h]; Plate Compactor [28 h]; Vibrators [28 h]; Water Tanker [28 h]; JCB [28 h] | 25,010.02 | 0 | 0 | 0.0037003381 | 6 | RPI - CONS | Z2 | PW | MECH | 1.3.3.40 | CONS | CONS | ZONE-3 | MECH | SEWER |
| CON-Z3-UT-SS-VC-0840 |  | Installation of Roof Slab, Manhole Cover, Accessories & Finishes | 5.6d | 2017-05-11 | 2017-05-17 | CON-Z3-UT-SS-VC-0700 FS+30d, CON-Z3-UT-SS-VC-0830 FS+4.8d | 76.2d | 0d | Common Labor / Helper [52 h]; Finishing Work Crew [52 h] | 30,012.02 | 0 | 0 | 0.002466885 | 6 | RPI - CONS | Z2 | PW | MECH | 1.3.3.40 | CONS | CONS | ZONE-3 | MECH | SEWER |

Notes:
- CON-Z3-UT-SS-VC-0570: Expenses: (New Expense Item) 12505
- CON-Z3-UT-SS-VC-0580: Expenses: (New Expense Item) 7503
- CON-Z3-UT-SS-VC-0610: Expenses: (New Expense Item) 12505
- CON-Z3-UT-SS-VC-0590: Expenses: (New Expense Item) 12505
- CON-Z3-UT-SS-VC-0600: Expenses: (New Expense Item) 12505
- CON-Z3-UT-SS-VC-0630: Expenses: (New Expense Item) 25010
- CON-Z3-UT-SS-VC-0620: Expenses: (New Expense Item) 12505
- CON-Z3-UT-SS-VC-0640: Expenses: (New Expense Item) 25010
- CON-Z3-UT-SS-VC-0650: Expenses: (New Expense Item) 12505
- CON-Z3-UT-SS-VC-0670: Expenses: (New Expense Item) 7503
- CON-Z3-UT-SS-VC-0660: Expenses: (New Expense Item) 50020
- CON-Z3-UT-SS-VC-0680: Expenses: (New Expense Item) 5002
- CON-Z3-UT-SS-VC-0690: Expenses: (New Expense Item) 25010
- CON-Z3-UT-SS-VC-0700: Expenses: (New Expense Item) 30012
- CON-Z3-UT-SS-VC-0710: Expenses: (New Expense Item) 12505
- CON-Z3-UT-SS-VC-0720: Expenses: (New Expense Item) 7503
- CON-Z3-UT-SS-VC-0750: Expenses: (New Expense Item) 12505
- CON-Z3-UT-SS-VC-0730: Expenses: (New Expense Item) 12505
- CON-Z3-UT-SS-VC-0740: Expenses: (New Expense Item) 12505
- CON-Z3-UT-SS-VC-0770: Expenses: (New Expense Item) 25010
- CON-Z3-UT-SS-VC-0760: Expenses: (New Expense Item) 12505
- CON-Z3-UT-SS-VC-0780: Expenses: (New Expense Item) 25010
- CON-Z3-UT-SS-VC-0790: Expenses: (New Expense Item) 12505
- CON-Z3-UT-SS-VC-0810: Expenses: (New Expense Item) 7503
- CON-Z3-UT-SS-VC-0800: Expenses: (New Expense Item) 50020
- CON-Z3-UT-SS-VC-0820: Expenses: (New Expense Item) 5002
- CON-Z3-UT-SS-VC-0830: Expenses: (New Expense Item) 25010
- CON-Z3-UT-SS-VC-0840: Expenses: (New Expense Item) 30012

| ID | WBS | Activity | Duration | Start | Finish | Predecessors | Total float | Free float | Resources | Cost | Activity Wt% | Weight % | Cost Wt | RPI - PHASE | RPI - CONSTRUCTION | RPI - ZONES | RPI - UTILITY NETWORKS | RPI - TYPE OF WORK | RPI_P2 - BOQ ITEMS | RPI_P2 - CONSTRUCTION | RPI_P2 - PHASE | RPI_P2 - ZONES | RPI_P2 - DISCIPLINE / WORK TYPE | RPI_P2 - UTILITY NETWORK |
| --- | --- | --- | --- | --- | --- | --- | --- | --- | --- | --- | --- | --- | --- | --- | --- | --- | --- | --- | --- | --- | --- | --- | --- | --- |
|  | 7 | **Air Release Valve Chamber (AV-4)** |  | 2017-03-07 | 2017-05-24 |  |  |  |  |  |  |  |  |  |  |  |  |  |  |  |  |  |  |  |
| CON-Z3-UT-SS-VC-0850 |  | Excavation and Compaction | 1.6d | 2017-03-07 | 2017-03-08 | CON-Z3-UT-SS-VC-0710 FS+5d | 78.2d | 0d | Operator - Excavator [26 h] | 12,505.01 | 0 | 0 | 0.0030836221 | 6 | RPI - CONS | Z2 | PW | MECH | 1.3.3.40 | CONS | CONS | ZONE-3 | MECH | SEWER |
| CON-Z3-UT-SS-VC-0860 |  | Lean concrete | 0.8d | 2017-03-09 | 2017-03-09 | CON-Z3-UT-SS-VC-0850 | 79.2d | 0d | Concrete Mason [52 h]; Driver - Conc. Transit Mixers [26 h]; Operator - Concrete Pump [26 h] | 7,503 | 0 | 0 | 0.0003088871 | 6 | RPI - CONS | Z2 | PW | MECH | 1.3.3.40 | CONS | CONS | ZONE-3 | MECH | SEWER |
| CON-Z3-UT-SS-VC-0890 |  | Formwork for Base Slab | 0.8d | 2017-03-09 | 2017-03-11 | CON-Z3-UT-SS-VC-0860 | 79.2d | 0d | Shuttering Carpenter [31.2 h]; Common Labor / Helper [20.8 h] | 12,505.01 | 0 | 0 | 0.000308358 | 6 | RPI - CONS | Z2 | PW | MECH | 1.3.3.40 | CONS | CONS | ZONE-3 | MECH | SEWER |
| CON-Z3-UT-SS-VC-0870 |  | Fabrication & installation of Rebar for Base Slab | 4d | 2017-03-11 | 2017-03-15 | CON-Z3-UT-SS-VC-0890 | 79.2d | 0d | Steel Fixer [78 h] | 12,505.01 | 0 | 0 | 0.0015418111 | 6 | RPI - CONS | Z2 | PW | MECH | 1.3.3.40 | CONS | CONS | ZONE-3 | MECH | SEWER |
| CON-Z3-UT-SS-VC-0880 |  | Fabrication & installation of Rebar for Side walls | 4d | 2017-03-15 | 2017-03-20 | CON-Z3-UT-SS-VC-0870 | 79.2d | 0d | Steel Fixer [78 h] | 12,505.01 | 0 | 0 | 0.0030836221 | 6 | RPI - CONS | Z2 | PW | MECH | 1.3.3.40 | CONS | CONS | ZONE-3 | MECH | SEWER |
| CON-Z3-UT-SS-VC-0910 |  | Formwork for side walls | 4d | 2017-03-16 | 2017-03-21 | CON-Z3-UT-SS-VC-0880 SS+0.8d | 79.2d | 0d | Shuttering Carpenter [78 h]; Common Labor / Helper [26 h]; Scaffolder [52 h] | 25,010.02 | 0 | 0 | 0.0015418111 | 6 | RPI - CONS | Z2 | PW | MECH | 1.3.3.40 | CONS | CONS | ZONE-3 | MECH | SEWER |
| CON-Z3-UT-SS-VC-0900 |  | Concrete pouring for base slab | 0.8d | 2017-03-21 | 2017-03-22 | CON-Z3-UT-SS-VC-0910 | 79.2d | 0d | Concrete Mason [20.8 h]; Common Labor / Helper [26 h]; Finishing Work Crew [20.8 h]; Driver - Conc. Transit Mixers [26 h]; Operator - Concrete Pump [26 h] | 12,505.01 | 0 | 0 | 0.0015418111 | 6 | RPI - CONS | Z2 | PW | MECH | 1.3.3.40 | CONS | CONS | ZONE-3 | MECH | SEWER |
| CON-Z3-UT-SS-VC-0920 |  | Concrete pouring for Side Wall | 0.8d | 2017-03-22 | 2017-03-22 | CON-Z3-UT-SS-VC-0900 | 79.2d | 0d | Concrete Mason [78 h]; Common Labor / Helper [26 h]; Finishing Work Crew [52 h]; Driver - Conc. Transit Mixers [26 h]; Operator - Concrete Pump [26 h] | 25,010.02 | 0 | 0 | 0.0040086961 | 6 | RPI - CONS | Z2 | PW | MECH | 1.3.3.40 | CONS | CONS | ZONE-3 | MECH | SEWER |
| CON-Z3-UT-SS-VC-0930 |  | Formwork removal and concrete patching | 1.6d | 2017-03-23 | 2017-03-25 | CON-Z3-UT-SS-VC-0920 | 79.2d | 0d | Shuttering Carpenter [78 h]; Scaffolder [26 h]; Finishing Work Crew [52 h] | 12,505.01 | 0 | 0 | 0.0015418111 | 6 | RPI - CONS | Z2 | PW | MECH | 1.3.3.40 | CONS | CONS | ZONE-3 | MECH | SEWER |
| CON-Z3-UT-SS-VC-0950 |  | Concrete Supports | 0.8d | 2017-03-25 | 2017-03-26 | CON-Z3-UT-SS-VC-0930 | 79.2d | 0d | Shuttering Carpenter [10.4 h]; Concrete Mason [10.4 h]; Common Labor / Helper [10.4 h] | 7,503 | 0 | 0 | 0.000616716 | 6 | RPI - CONS | Z2 | PW | MECH | 1.3.3.40 | CONS | CONS | ZONE-3 | MECH | SEWER |
| CON-Z3-UT-SS-VC-0940 |  | Installation of Valves ,Fittings/ Pipe Connections / Closing of Openings | 8d | 2017-03-26 | 2017-04-04 | CON-Z3-UT-SS-VC-0950 | 79.2d | 0d | Shuttering Carpenter [26 h]; Concrete Mason [26 h]; Common Labor / Helper [26 h]; RTR Pipe Crew [26 h] | 50,020.03 | 0 | 0 | 0.0055505071 | 6 | RPI - CONS | Z2 | PW | MECH | 1.3.3.40 | CONS | CONS | ZONE-3 | MECH | SEWER |
| CON-Z3-UT-SS-VC-0960 |  | Damp Proof Coating | 0.8d | 2017-04-04 | 2017-04-05 | CON-Z3-UT-SS-VC-0940, CON-Z3-UT-SS-VC-0930 | 79.2d | 0d | Painter [52 h]; Water Proofing Crew [52 h] | 5,002 | 0 | 0 | 0.0015418111 | 6 | RPI - CONS | Z2 | PW | MECH | 1.3.3.40 | CONS | CONS | ZONE-3 | MECH | SEWER |
| CON-Z3-UT-SS-VC-0970 |  | Backfilling & Compaction | 4d | 2017-05-04 | 2017-05-09 | CON-Z3-UT-SS-VC-0960 FS+25d | 79.2d | 3d | Common Labor / Helper [52 h]; Driver - Dump Truck [26 h]; Operator - Bobcat [26 h]; Operator - Roller-Compactor (2~10 Ton) [26 h]; Driver - Water Tanker [26 h]; Operator - JCB [26 h]; Bobcat [28 h]; Plate Compactor [28 h]; Vibrators [28 h]; Water Tanker [28 h]; JCB [28 h] | 25,010.02 | 0 | 0 | 0.0037003381 | 6 | RPI - CONS | Z2 | PW | MECH | 1.3.3.40 | CONS | CONS | ZONE-3 | MECH | SEWER |
| CON-Z3-UT-SS-VC-0980 |  | Installation of Roof Slab, Manhole Cover, Accessories & Finishes | 5.6d | 2017-05-18 | 2017-05-24 | CON-Z3-UT-SS-VC-0970 FS+4.8d, CON-Z3-UT-SS-VC-0840 | 76.2d | 0d | Common Labor / Helper [52 h]; Finishing Work Crew [52 h] | 30,012.02 | 0 | 0 | 0.002466885 | 6 | RPI - CONS | Z2 | PW | MECH | 1.3.3.40 | CONS | CONS | ZONE-3 | MECH | SEWER |
|  | 8 | **Air Release Valve Chamber (AV-2B)** |  | 2017-03-15 | 2017-05-31 |  |  |  |  |  |  |  |  |  |  |  |  |  |  |  |  |  |  |  |
| CON-Z3-UT-SS-VC-0990 |  | Excavation and Compaction | 1.6d | 2017-03-15 | 2017-03-16 | CON-Z3-UT-SS-VC-0850 FS+5d | 78.2d | 0d | Operator - Excavator [26 h] | 12,505.01 | 0 | 0 | 0.0030836221 | 6 | RPI - CONS | Z2 | PW | MECH | 1.3.3.40 | CONS | CONS | ZONE-3 | MECH | SEWER |
| CON-Z3-UT-SS-VC-1000 |  | Lean concrete | 0.8d | 2017-03-16 | 2017-03-18 | CON-Z3-UT-SS-VC-0990 | 78.2d | 0d | Concrete Mason [10.4 h]; Driver - Conc. Transit Mixers [10.4 h]; Operator - Concrete Pump [10.4 h] | 7,503 | 0 | 0 | 0.0003088871 | 6 | RPI - CONS | Z2 | PW | MECH | 1.3.3.40 | CONS | CONS | ZONE-3 | MECH | SEWER |
| CON-Z3-UT-SS-VC-1030 |  | Formwork for Base Slab | 0.8d | 2017-03-18 | 2017-03-19 | CON-Z3-UT-SS-VC-1000 | 78.2d | 0d | Shuttering Carpenter [31.2 h]; Common Labor / Helper [20.8 h] | 12,505.01 | 0 | 0 | 0.000308358 | 6 | RPI - CONS | Z2 | PW | MECH | 1.3.3.40 | CONS | CONS | ZONE-3 | MECH | SEWER |
| CON-Z3-UT-SS-VC-1010 |  | Fabrication & installation of Rebar for Base Slab | 4d | 2017-03-19 | 2017-03-23 | CON-Z3-UT-SS-VC-1030 | 78.2d | 0d | Steel Fixer [78 h] | 12,505.01 | 0 | 0 | 0.0015418111 | 6 | RPI - CONS | Z2 | PW | MECH | 1.3.3.40 | CONS | CONS | ZONE-3 | MECH | SEWER |
| CON-Z3-UT-SS-VC-1020 |  | Fabrication & installation of Rebar for Side walls | 4d | 2017-03-23 | 2017-03-28 | CON-Z3-UT-SS-VC-1010 | 78.2d | 0d | Steel Fixer [78 h] | 12,505.01 | 0 | 0 | 0.0030836221 | 6 | RPI - CONS | Z2 | PW | MECH | 1.3.3.40 | CONS | CONS | ZONE-3 | MECH | SEWER |
| CON-Z3-UT-SS-VC-1050 |  | Formwork for side walls | 4d | 2017-03-25 | 2017-03-28 | CON-Z3-UT-SS-VC-1020 SS+0.8d | 78.2d | 0d | Shuttering Carpenter [78 h]; Common Labor / Helper [26 h]; Scaffolder [52 h] | 25,010.02 | 0 | 0 | 0.0015418111 | 6 | RPI - CONS | Z2 | PW | MECH | 1.3.3.40 | CONS | CONS | ZONE-3 | MECH | SEWER |
| CON-Z3-UT-SS-VC-1040 |  | Concrete pouring for base slab | 0.8d | 2017-03-29 | 2017-03-29 | CON-Z3-UT-SS-VC-1050 | 78.2d | 0d | Concrete Mason [78 h]; Common Labor / Helper [26 h]; Finishing Work Crew [52 h]; Driver - Conc. Transit Mixers [26 h]; Operator - Concrete Pump [26 h] | 12,505.01 | 0 | 0 | 0.0015418111 | 6 | RPI - CONS | Z2 | PW | MECH | 1.3.3.40 | CONS | CONS | ZONE-3 | MECH | SEWER |
| CON-Z3-UT-SS-VC-1060 |  | Concrete pouring for Side Wall | 0.8d | 2017-03-29 | 2017-03-30 | CON-Z3-UT-SS-VC-1040 | 78.2d | 0d | Concrete Mason [20.8 h]; Common Labor / Helper [26 h]; Finishing Work Crew [31.2 h]; Driver - Conc. Transit Mixers [26 h]; Operator - Concrete Pump [26 h] | 25,010.02 | 0 | 0 | 0.0040086961 | 6 | RPI - CONS | Z2 | PW | MECH | 1.3.3.40 | CONS | CONS | ZONE-3 | MECH | SEWER |
| CON-Z3-UT-SS-VC-1070 |  | Formwork removal and concrete patching | 1.6d | 2017-03-30 | 2017-04-02 | CON-Z3-UT-SS-VC-1060 | 78.2d | 0d | Shuttering Carpenter [78 h]; Scaffolder [26 h]; Finishing Work Crew [52 h] | 12,505.01 | 0 | 0 | 0.0015418111 | 6 | RPI - CONS | Z2 | PW | MECH | 1.3.3.40 | CONS | CONS | ZONE-3 | MECH | SEWER |
| CON-Z3-UT-SS-VC-1090 |  | Concrete Supports | 0.8d | 2017-04-02 | 2017-04-02 | CON-Z3-UT-SS-VC-1070 | 78.2d | 0d | Shuttering Carpenter [26 h]; Concrete Mason [26 h]; Common Labor / Helper [26 h] | 7,503 | 0 | 0 | 0.000616716 | 6 | RPI - CONS | Z2 | PW | MECH | 1.3.3.40 | CONS | CONS | ZONE-3 | MECH | SEWER |
| CON-Z3-UT-SS-VC-1080 |  | Installation of Valves ,Fittings/ Pipe Connections / Closing of Openings | 8d | 2017-05-02 | 2017-05-10 | CON-Z3-UT-SS-VC-1090 FS+25d | 78.2d | 0d | Shuttering Carpenter [26 h]; Concrete Mason [26 h]; Common Labor / Helper [26 h]; RTR Pipe Crew [26 h] | 50,020.03 | 0 | 0 | 0.0055505071 | 6 | RPI - CONS | Z2 | PW | MECH | 1.3.3.40 | CONS | CONS | ZONE-3 | MECH | SEWER |
| CON-Z3-UT-SS-VC-1100 |  | Damp Proof Coating | 0.8d | 2017-05-11 | 2017-05-11 | CON-Z3-UT-SS-VC-1070, CON-Z3-UT-SS-VC-1080 | 78.2d | 0d | Painter [52 h]; Water Proofing Crew [52 h] | 5,002 | 0 | 0 | 0.0015418111 | 6 | RPI - CONS | Z2 | PW | MECH | 1.3.3.40 | CONS | CONS | ZONE-3 | MECH | SEWER |
| CON-Z3-UT-SS-VC-1110 |  | Backfilling & Compaction | 4d | 2017-05-11 | 2017-05-16 | CON-Z3-UT-SS-VC-1100 | 78.2d | 2d | Common Labor / Helper [52 h]; Driver - Dump Truck [26 h]; Operator - Bobcat [26 h]; Operator - Roller-Compactor (2~10 Ton) [26 h]; Driver - Water Tanker [26 h]; Operator - JCB [26 h]; Bobcat [28 h]; Plate Compactor [28 h]; Vibrators [28 h]; Water Tanker [28 h]; JCB [28 h] | 25,010.02 | 0 | 0 | 0.0037003381 | 6 | RPI - CONS | Z2 | PW | MECH | 1.3.3.40 | CONS | CONS | ZONE-3 | MECH | SEWER |
| CON-Z3-UT-SS-VC-1120 |  | Installation of Roof Slab, Manhole Cover, Accessories & Finishes | 5.6d | 2017-05-24 | 2017-05-31 | CON-Z3-UT-SS-VC-0980, CON-Z3-UT-SS-VC-1110 FS+4.8d | 76.2d | 0d | Common Labor / Helper [52 h]; Finishing Work Crew [52 h] | 30,012.02 | 0 | 0 | 0.002466885 | 6 | RPI - CONS | Z2 | PW | MECH | 1.3.3.40 | CONS | CONS | ZONE-3 | MECH | SEWER |

Notes:
- CON-Z3-UT-SS-VC-0850: Expenses: (New Expense Item) 12505
- CON-Z3-UT-SS-VC-0860: Expenses: (New Expense Item) 7503
- CON-Z3-UT-SS-VC-0890: Expenses: (New Expense Item) 12505
- CON-Z3-UT-SS-VC-0870: Expenses: (New Expense Item) 12505
- CON-Z3-UT-SS-VC-0880: Expenses: (New Expense Item) 12505
- CON-Z3-UT-SS-VC-0910: Expenses: (New Expense Item) 25010
- CON-Z3-UT-SS-VC-0900: Expenses: (New Expense Item) 12505
- CON-Z3-UT-SS-VC-0920: Expenses: (New Expense Item) 25010
- CON-Z3-UT-SS-VC-0930: Expenses: (New Expense Item) 12505
- CON-Z3-UT-SS-VC-0950: Expenses: (New Expense Item) 7503
- CON-Z3-UT-SS-VC-0940: Expenses: (New Expense Item) 50020
- CON-Z3-UT-SS-VC-0960: Expenses: (New Expense Item) 5002
- CON-Z3-UT-SS-VC-0970: Expenses: (New Expense Item) 25010
- CON-Z3-UT-SS-VC-0980: Expenses: (New Expense Item) 30012
- CON-Z3-UT-SS-VC-0990: Expenses: (New Expense Item) 12505
- CON-Z3-UT-SS-VC-1000: Expenses: (New Expense Item) 7503
- CON-Z3-UT-SS-VC-1030: Expenses: (New Expense Item) 12505
- CON-Z3-UT-SS-VC-1010: Expenses: (New Expense Item) 12505
- CON-Z3-UT-SS-VC-1020: Expenses: (New Expense Item) 12505
- CON-Z3-UT-SS-VC-1050: Expenses: (New Expense Item) 25010
- CON-Z3-UT-SS-VC-1040: Expenses: (New Expense Item) 12505
- CON-Z3-UT-SS-VC-1060: Expenses: (New Expense Item) 25010
- CON-Z3-UT-SS-VC-1070: Expenses: (New Expense Item) 12505
- CON-Z3-UT-SS-VC-1090: Expenses: (New Expense Item) 7503
- CON-Z3-UT-SS-VC-1080: Expenses: (New Expense Item) 50020
- CON-Z3-UT-SS-VC-1100: Expenses: (New Expense Item) 5002
- CON-Z3-UT-SS-VC-1110: Expenses: (New Expense Item) 25010
- CON-Z3-UT-SS-VC-1120: Expenses: (New Expense Item) 30012

| ID | WBS | Activity | Duration | Start | Finish | Predecessors | Total float | Free float | Resources | Cost | Activity Wt% | Weight % | Cost Wt | RPI - PHASE | RPI - CONSTRUCTION | RPI - ZONES | RPI - UTILITY NETWORKS | RPI - TYPE OF WORK | RPI_P2 - BOQ ITEMS | RPI_P2 - CONSTRUCTION | RPI_P2 - PHASE | RPI_P2 - ZONES | RPI_P2 - DISCIPLINE / WORK TYPE | RPI_P2 - UTILITY NETWORK | RPI_P2 - AREAS |
| --- | --- | --- | --- | --- | --- | --- | --- | --- | --- | --- | --- | --- | --- | --- | --- | --- | --- | --- | --- | --- | --- | --- | --- | --- | --- |
|  | 9 | **Slow Down Chamber (SDC-2)** |  | 2017-03-22 | 2017-06-06 |  |  |  |  |  |  |  |  |  |  |  |  |  |  |  |  |  |  |  |  |
| CON-Z3-UT-SS-VC-1130 |  | Excavation and Compaction | 1.6d | 2017-03-22 | 2017-03-25 | CON-Z3-UT-SS-VC-0990 FS+5d | 91d | 0d | Operator - Excavator [26 h] | 12,505.01 | 0 | 0 | 0.0030836221 | 6 | RPI - CONS | Z2 | PW | MECH | 1.3.3.40 | CONS | CONS | ZONE-3 | MECH | SEWER |  |
| CON-Z3-UT-SS-VC-1140 |  | Lean concrete | 0.8d | 2017-03-25 | 2017-03-25 | CON-Z3-UT-SS-VC-1130 | 91d | 0d | Concrete Mason [10.4 h]; Driver - Conc. Transit Mixers [10.4 h]; Operator - Concrete Pump [10.4 h] | 7,503 | 0 | 0 | 0.0003088871 | 6 | RPI - CONS | Z2 | PW | MECH | 1.3.3.40 | CONS | CONS | ZONE-3 | MECH | SEWER |  |
| CON-Z3-UT-SS-VC-1150 |  | Formwork for Base Slab | 0.8d | 2017-03-26 | 2017-03-26 | CON-Z3-UT-SS-VC-1140 | 91d | 0d | Shuttering Carpenter [31.2 h]; Common Labor / Helper [20.8 h] | 12,505.01 | 0 | 0 | 0.000308358 | 6 | RPI - CONS | Z2 | PW | MECH | 1.3.3.40 | CONS | CONS | ZONE-3 | MECH | SEWER |  |
| CON-Z3-UT-SS-VC-1240 |  | Fabrication & installation of Rebar for Base Slab | 4d | 2017-03-26 | 2017-03-30 | CON-Z3-UT-SS-VC-1150 | 91d | 0d | Steel Fixer [78 h] | 5,002 | 0 | 0 | 0.0015418111 | 6 | RPI - CONS | Z2 | PW | MECH | 1.3.3.40 | CONS | CONS | ZONE-3 | MECH | SEWER |  |
| CON-Z3-UT-SS-VC-1250 |  | Fabrication & installation of Rebar for Side walls | 4d | 2017-03-30 | 2017-04-04 | CON-Z3-UT-SS-VC-1240 | 91d | 0d | Steel Fixer [78 h] | 25,010.02 | 0 | 0 | 0.0030836221 | 6 | RPI - CONS | Z2 | PW | MECH | 1.3.3.40 | CONS | CONS | ZONE-3 | MECH | SEWER |  |
| CON-Z3-UT-SS-VC-1170 |  | Formwork for side walls | 4d | 2017-04-01 | 2017-04-05 | CON-Z3-UT-SS-VC-1250 SS+0.8d | 91d | 0d | Shuttering Carpenter [78 h]; Common Labor / Helper [26 h]; Scaffolder [52 h] | 12,505.01 | 0 | 0 | 0.0015418111 | 6 | RPI - CONS | Z2 | PW | MECH | 1.3.3.40 | CONS | CONS | ZONE-3 | MECH | SEWER |  |
| CON-Z3-UT-SS-VC-1160 |  | Concrete pouring for base slab | 0.8d | 2017-04-05 | 2017-04-06 | CON-Z3-UT-SS-VC-1170 | 91d | 0d | Concrete Mason [78 h]; Common Labor / Helper [26 h]; Finishing Work Crew [52 h]; Driver - Conc. Transit Mixers [26 h]; Operator - Concrete Pump [26 h] | 12,505.01 | 0 | 0 | 0.0015418111 | 6 | RPI - CONS | Z2 | PW | MECH | 1.3.3.40 | CONS | CONS | ZONE-3 | MECH | SEWER |  |
| CON-Z3-UT-SS-VC-1180 |  | Concrete pouring for Side Wall | 0.8d | 2017-04-06 | 2017-04-08 | CON-Z3-UT-SS-VC-1160 | 91d | 0d | Concrete Mason [78 h]; Common Labor / Helper [26 h]; Finishing Work Crew [52 h]; Driver - Conc. Transit Mixers [26 h]; Operator - Concrete Pump [26 h] | 12,505.01 | 0 | 0 | 0.0040086961 | 6 | RPI - CONS | Z2 | PW | MECH | 1.3.3.40 | CONS | CONS | ZONE-3 | MECH | SEWER |  |
| CON-Z3-UT-SS-VC-1190 |  | Formwork removal and concrete patching | 1.6d | 2017-04-08 | 2017-04-09 | CON-Z3-UT-SS-VC-1180 | 91d | 0d | Shuttering Carpenter [78 h]; Scaffolder [26 h]; Finishing Work Crew [52 h] | 25,010.02 | 0 | 0 | 0.0015418111 | 6 | RPI - CONS | Z2 | PW | MECH | 1.3.3.40 | CONS | CONS | ZONE-3 | MECH | SEWER |  |
| CON-Z3-UT-SS-VC-1210 |  | Concrete Supports | 0.8d | 2017-04-09 | 2017-04-10 | CON-Z3-UT-SS-VC-1190 | 102.2d | 0d | Shuttering Carpenter [26 h]; Concrete Mason [26 h]; Common Labor / Helper [26 h] | 12,505.01 | 0 | 0 | 0.000616716 | 6 | RPI - CONS | Z2 | PW | MECH | 1.3.3.40 | CONS | CONS | ZONE-3 | MECH | SEWER |  |
| CON-Z3-UT-SS-VC-1200 |  | Installation of Valves ,Fittings/ Pipe Connections / Closing of Openings | 8d | 2017-04-10 | 2017-04-19 | CON-Z3-UT-SS-VC-1210 | 102.2d | 11.2d | Shuttering Carpenter [26 h]; Concrete Mason [26 h]; Common Labor / Helper [26 h]; RTR Pipe Crew [26 h] | 25,010.02 | 0 | 0 | 0.0055505071 | 6 | RPI - CONS | Z2 | PW | MECH | 1.3.3.40 | CONS | CONS | ZONE-3 | MECH | SEWER |  |
| CON-Z3-UT-SS-VC-1220 |  | Damp Proof Coating | 0.8d | 2017-05-02 | 2017-05-03 | CON-Z3-UT-SS-VC-1190 FS+20d, CON-Z3-UT-SS-VC-1200 | 91d | 0d | Painter [52 h]; Water Proofing Crew [52 h] | 50,020.03 | 0 | 0 | 0.0015418111 | 6 | RPI - CONS | Z2 | PW | MECH | 1.3.3.40 | CONS | CONS | ZONE-3 | MECH | SEWER |  |
| CON-Z3-UT-SS-VC-1230 |  | Backfilling & Compaction | 4d | 2017-05-03 | 2017-05-08 | CON-Z3-UT-SS-VC-1220 | 91d | 14.8d | Common Labor / Helper [52 h]; Driver - Dump Truck [26 h]; Operator - Bobcat [26 h]; Operator - Roller-Compactor (2~10 Ton) [26 h]; Driver - Water Tanker [26 h]; Operator - JCB [26 h]; Bobcat [28 h]; Plate Compactor [28 h]; Vibrators [28 h]; Water Tanker [28 h]; JCB [28 h] | 7,503 | 0 | 0 | 0.0037003381 | 6 | RPI - CONS | Z2 | PW | MECH | 1.3.3.40 | CONS | CONS | ZONE-3 | MECH | SEWER |  |
| CON-Z3-UT-SS-VC-1260 |  | Installation of Roof Slab, Manhole Cover, Accessories & Finishes | 5.6d | 2017-05-31 | 2017-06-06 | CON-Z3-UT-SS-VC-1120, CON-Z3-UT-SS-VC-1230 FS+4.8d | 76.2d | 46d | Common Labor / Helper [52 h]; Finishing Work Crew [52 h] | 30,012.02 | 0 | 0 | 0.002466885 | 6 | RPI - CONS | Z2 | PW | MECH | 1.3.3.40 | CONS | CONS | ZONE-3 | MECH | SEWER |  |
|  | 10 | **Interfaces and Tie in Connections With Existing KAUST Utilities** |  | 2017-07-15 | 2017-08-01 |  |  |  |  |  |  |  |  |  |  |  |  |  |  |  |  |  |  |  |  |
| CON-SZ3-SS-TIE-0010 |  | Gravity Sewer Line to LS#10 & LS#11 Interface With SS#4, SS#5 and AEB | 8d | 2017-07-15 | 2017-07-24 | CON-Z3-UT-FM-PL-0240 SS, CON-Z3-UT-GRV-PL-390 | 32.6d | 0d | Plumber [80 h]; Common Labor / Helper [80 h] | 50,020.03 |  |  |  |  |  |  |  |  | 1.3.3.40 | CONS | CONS | ZONE-3 | MECH | SEWER |  |
| CON-SZ3-SS-TIE-0020 |  | Rd-1 Crossing Near Gate #1 From LS#9 to LS#10 | 8d | 2017-07-17 | 2017-07-26 | CON-SZ3-SS-TIE-0010 SS+2.4d | 32.6d | 0d | Plumber [640 h]; Common Labor / Helper [520 h] | 75,030.05 |  |  |  |  |  |  |  |  | 1.3.3.40 | CONS | CONS | ZONE-3 | MECH | SEWER |  |
| CON-SZ3-SS-TIE-0030 |  | Rd-4 Crossing From Sewer Manhole SMH-RL-4 to SMH-08-R4 | 8d | 2017-07-20 | 2017-07-29 | CON-SZ3-SS-TIE-0020 SS+2.4d | 32.6d | 0d | Plumber [640 h]; Common Labor / Helper [520 h] | 50,020.03 |  |  |  |  |  |  |  |  | 1.3.3.40 | CONS | CONS | ZONE-3 | MECH | SEWER |  |
| CON-SZ3-SS-TIE-0040 |  | Proposed New STP Interface With Pipes for Sewer Force-main Line From LS#10 and LS#12 ( At VB#1) | 8d | 2017-07-23 | 2017-08-01 | CON-SZ3-SS-TIE-0030 SS+2.4d | 32.6d | 2.4d | Plumber [640 h]; Common Labor / Helper [520 h] | 75,030.05 |  |  |  |  |  |  |  |  | 1.3.3.40 | CONS | CONS | ZONE-3 | MECH | SEWER |  |
|  | 5 | **Irrigation Water System** |  | 2016-11-14 | 2017-08-30 |  |  |  |  |  |  |  |  |  |  |  |  |  |  |  |  |  |  |  |  |
|  | 15 | **Irrigation Line - Upvc 200mm dia at Road A = 1430 Lm** |  | 2016-11-14 | 2016-12-31 |  |  |  |  |  |  |  |  |  |  |  |  |  |  |  |  |  |  |  |  |
| CON-Z3-UT-IRG-PL-010 |  | Installation of Thurst Blocks of already installed Pipe line | 15d | 2016-11-14 | 2016-12-01 | CON-CON-CON-CON-0010 FS+79d | 27.8d | 0d | Steel Fixer [585 h]; Shuttering Carpenter [585 h]; Concrete Mason [585 h]; Common Labor / Helper [75 h]; Driver - Conc. Transit Mixers [195 h]; Operator - Concrete Pump [195 h]; Concrete Transit Mixers [210 h]; Concrete Pump [210 h] | 65,700 |  |  |  |  |  |  |  |  | 1.3.3.50 | CONS | CONS | ZONE-3 | MECH | IRR | ROAD-A |
| CON-Z3-UT-IRG-PL-020 |  | Testing and Precommissioning | 25d | 2016-12-01 | 2016-12-31 | CON-Z3-UT-IRG-PL-010 | 37.8d | 10d | RTR Pipe Crew [52 h]; Driver - Water Tanker [26 h]; Water Tanker [28 h]; Plumber [52 h]; Common Labor / Helper [52 h] | 262,800 |  |  |  |  |  |  |  |  | 1.3.3.50 | CONS | CONS | ZONE-3 | MECH | IRR | ROAD-A |

Notes:
- CON-Z3-UT-SS-VC-1130: Expenses: (New Expense Item) 12505
- CON-Z3-UT-SS-VC-1140: Expenses: (New Expense Item) 7503
- CON-Z3-UT-SS-VC-1150: Expenses: (New Expense Item) 12505
- CON-Z3-UT-SS-VC-1240: Expenses: (New Expense Item) 5002
- CON-Z3-UT-SS-VC-1250: Expenses: (New Expense Item) 25010
- CON-Z3-UT-SS-VC-1170: Expenses: (New Expense Item) 12505
- CON-Z3-UT-SS-VC-1160: Expenses: (New Expense Item) 12505
- CON-Z3-UT-SS-VC-1180: Expenses: (New Expense Item) 12505
- CON-Z3-UT-SS-VC-1190: Expenses: (New Expense Item) 25010
- CON-Z3-UT-SS-VC-1210: Expenses: (New Expense Item) 12505
- CON-Z3-UT-SS-VC-1200: Expenses: (New Expense Item) 25010
- CON-Z3-UT-SS-VC-1220: Expenses: (New Expense Item) 50020
- CON-Z3-UT-SS-VC-1230: Expenses: (New Expense Item) 7503
- CON-Z3-UT-SS-VC-1260: Expenses: (New Expense Item) 30012
- CON-SZ3-SS-TIE-0010: Expenses: (New Expense Item) 50020
- CON-SZ3-SS-TIE-0020: Expenses: (New Expense Item) 75030.1
- CON-SZ3-SS-TIE-0030: Expenses: (New Expense Item) 50020
- CON-SZ3-SS-TIE-0040: Expenses: (New Expense Item) 75030.1
- CON-Z3-UT-IRG-PL-010: Expenses: (New Expense Item) 65700
- CON-Z3-UT-IRG-PL-020: Expenses: (New Expense Item) 262800

| ID | WBS | Activity | Duration | Start | Finish | Predecessors | Total float | Free float | Resources | Cost | RPI_P2 - BOQ ITEMS | RPI_P2 - CONSTRUCTION | RPI_P2 - PHASE | RPI_P2 - ZONES | RPI_P2 - AREAS | RPI_P2 - DISCIPLINE / WORK TYPE | RPI_P2 - UTILITY NETWORK |
| --- | --- | --- | --- | --- | --- | --- | --- | --- | --- | --- | --- | --- | --- | --- | --- | --- | --- |
|  | 2 | **Irrigation Line - Upvc 200mm dia at Road B = 542 Lm** |  | 2016-12-01 | 2017-01-05 |  |  |  |  |  |  |  |  |  |  |  |  |
| CON-Z3-UT-IRG-PL-030 |  | Installation of Thurst Blocks of already installed Pipe line | 10d | 2016-12-01 | 2016-12-13 | CON-Z3-UT-IRG-PL-010 | 27.8d | 0d | Steel Fixer [26 h]; Shuttering Carpenter [52 h]; Concrete Mason [52 h]; Common Labor / Helper [52 h]; Driver - Conc. Transit Mixers [26 h]; Operator - Concrete Pump [26 h]; Concrete Transit Mixers [28 h]; Concrete Pump [28 h] | 41,062.5 | 1.3.3.50 | CONS | CONS | ZONE-3 | ROAD-B | MECH | IRR |
| CON-Z3-UT-IRG-PL-040 |  | Testing and Precommissioning | 20d | 2016-12-13 | 2017-01-05 | CON-Z3-UT-IRG-PL-020 SS, CON-Z3-UT-IRG-PL-030 | 27.8d | 0d | Plumber [52 h]; Common Labor / Helper [52 h]; RTR Pipe Crew [52 h]; Driver - Water Tanker [26 h]; Water Tanker [28 h] | 164,250 | 1.3.3.50 | CONS | CONS | ZONE-3 | ROAD-B | MECH | IRR |
|  | 1 | **Irrigation Line - Upvc 200mm dia at Road 2 = 1217 Lm** |  | 2016-12-19 | 2017-05-30 |  |  |  |  |  |  |  |  |  |  |  |  |
| CON-Z3-UT-IRG-PL-050 |  | Excavation of Trench (138 Lm) | 0.8d | 2016-12-19 | 2016-12-19 | CON-Z3-UT-IRG-PL-040 SS+5d | 27.8d | 0d | Common Labor / Helper [26 h]; Operator - Excavator [26 h]; Driver - Dump Truck [26 h]; Operator - JCB [26 h]; Excavator [28 h]; Dump Truck [28 h] | 41,062.5 | 1.3.3.50 | CONS | CONS | ZONE-3 | ROAD-2 | MECH | IRR |
| CON-Z3-UT-IRG-PL-060 |  | Compaction and Sand bedding (138 Lm) | 1.6d | 2016-12-22 | 2016-12-24 | CON-Z3-UT-IRG-PL-050 SS+3.2d | 37.2d | 0d | Common Labor / Helper [52 h]; Operator - Loader [13 h]; Driver - Dump Truck [13 h]; Operator - Bobcat [13 h]; Operator - JCB [13 h] | 20,531.25 | 1.3.3.50 | CONS | CONS | ZONE-3 | ROAD-2 | MECH | IRR |
| CON-Z3-UT-IRG-PL-070 |  | Pipe Laying (138 Lm) | 3.2d | 2016-12-25 | 2016-12-28 | CON-Z3-UT-IRG-PL-060 SS+2.4d | 37.2d | 0d | Plumber [52 h]; Common Labor / Helper [78 h]; RTR Pipe Crew [52 h]; Operator - Mobile Crane [26 h]; Driver - Flat Bed Trailer [26 h]; Mobile Crane ( 25-60 Ton) [28 h]; Flat Bed Trailer [28 h] | 82,125 | 1.3.3.50 | CONS | CONS | ZONE-3 | ROAD-2 | MECH | IRR |
| CON-Z3-UT-IRG-PL-080 |  | Installation of Thurst Block (138 Lm) | 2d | 2016-12-29 | 2017-01-01 | CON-Z3-UT-IRG-PL-070 SS+4d | 37.2d | 0d | Operator - Concrete Pump [26 h]; Concrete Transit Mixers [28 h]; Concrete Pump [28 h]; Shuttering Carpenter [52 h]; Concrete Mason [52 h]; Steel Fixer [26 h]; Common Labor / Helper [52 h]; Driver - Conc. Transit Mixers [26 h] | 20,531.25 | 1.3.3.50 | CONS | CONS | ZONE-3 | ROAD-2 | MECH | IRR |
| CON-Z3-UT-IRG-PL-090 |  | Backfilling (1217 Lm) | 32d | 2017-01-01 | 2017-02-07 | CON-Z3-UT-IRG-PL-080, CON-Z3-UT-IRG-PL-070 | 37.2d | 0d | Common Labor / Helper [104 h]; Operator - Loader [26 h]; Driver - Dump Truck [26 h]; Operator - Bobcat [26 h]; Operator - Asphalt Compactor / Roller [26 h]; Operator - Roller-Compactor (2~10 Ton) [26 h]; Driver - Water Tanker [26 h]; Operator - JCB [26 h]; Loader [28 h]; Dump Truck [28 h]; Bobcat [28 h]; Roller-Compactor (2~10 Ton) [28 h]; Plate Compactor [28 h]; Vibrators [28 h]; Water Tanker [28 h]; JCB [28 h] | 102,656.25 | 1.3.3.50 | CONS | CONS | ZONE-3 | ROAD-2 | MECH | IRR |
| CON-Z3-UT-IRG-PL-480 |  | Testing and Precommissioning (1217 Lm) | 16d | 2017-05-11 | 2017-05-30 | CON-Z3-UT-IRG-PL-040 SS, CON-Z3-UT-IRG-PL-090 FS+80d | 37.2d | 0d | Plumber [52 h]; Common Labor / Helper [52 h]; RTR Pipe Crew [52 h]; Driver - Water Tanker [26 h]; Water Tanker [28 h] | 143,718.75 | 1.3.3.50 | CONS | CONS | ZONE-3 | ROAD-2 | MECH | IRR |
|  | 3 | **Irrigation Line - Upvc 200mm dia at Road 3 = 1843 Lm** |  | 2017-01-24 | 2017-07-02 |  |  |  |  |  |  |  |  |  |  |  |  |
| CON-Z3-UT-IRG-PL-100 |  | Excavation of Trench (80 Lm) | 0.8d | 2017-01-24 | 2017-01-24 | CON-Z3-UT-IRG-PL-050 FS+30d | 27.8d | 0d | Common Labor / Helper [39 h]; Operator - Excavator [13 h]; Driver - Dump Truck [13 h]; Operator - JCB [13 h]; Excavator [14 h]; Dump Truck [14 h] | 49,275 | 1.3.3.50 | CONS | CONS | ZONE-3 | ROAD-3 | MECH | IRR |
| CON-Z3-UT-IRG-PL-110 |  | Compaction and Sand bedding (80 Lm) | 1.6d | 2017-01-28 | 2017-01-29 | CON-Z3-UT-IRG-PL-100 SS+3.2d | 54.4d | 0d | Common Labor / Helper [52 h]; Operator - Loader [13 h]; Driver - Dump Truck [13 h]; Operator - Bobcat [13 h]; Operator - JCB [13 h] | 24,637.5 | 1.3.3.50 | CONS | CONS | ZONE-3 | ROAD-3 | MECH | IRR |
| CON-Z3-UT-IRG-PL-120 |  | Pipe Laying (80 Lm) | 1.6d | 2017-01-30 | 2017-02-01 | CON-Z3-UT-IRG-PL-110 SS+2.4d | 54.4d | 0d | Plumber [65 h]; Common Labor / Helper [39 h]; RTR Pipe Crew [26 h]; Operator - Mobile Crane [13 h]; Driver - Flat Bed Trailer [13 h]; Mobile Crane ( 25-60 Ton) [14 h]; Flat Bed Trailer [14 h] | 98,550 | 1.3.3.50 | CONS | CONS | ZONE-3 | ROAD-3 | MECH | IRR |
| CON-Z3-UT-IRG-PL-130 |  | Installation of Thurst Block (80 Lm) | 1d | 2017-02-04 | 2017-02-05 | CON-Z3-UT-IRG-PL-120 SS+4d | 54.4d | 2.2d | Steel Fixer [26 h]; Shuttering Carpenter [52 h]; Concrete Mason [52 h]; Common Labor / Helper [52 h]; Driver - Conc. Transit Mixers [26 h]; Operator - Concrete Pump [26 h]; Concrete Transit Mixers [28 h]; Concrete Pump [28 h] | 24,637.5 | 1.3.3.50 | CONS | CONS | ZONE-3 | ROAD-3 | MECH | IRR |
| CON-Z3-UT-IRG-PL-140 |  | Backfilling (1843 Lm) | 48d | 2017-02-07 | 2017-04-04 | CON-Z3-UT-IRG-PL-130, CON-Z3-UT-IRG-PL-120, CON-Z3-UT-IRG-PL-090 | 52.2d | 0d | Common Labor / Helper [104 h]; Operator - Loader [26 h]; Driver - Dump Truck [26 h]; Operator - Bobcat [26 h]; Operator - Asphalt Compactor / Roller [26 h]; Operator - Roller-Compactor (2~10 Ton) [26 h]; Driver - Water Tanker [26 h]; Operator - JCB [26 h]; Loader [28 h]; Dump Truck [28 h]; Bobcat [28 h]; Roller-Compactor (2~10 Ton) [28 h]; Plate Compactor [28 h]; Vibrators [28 h]; Water Tanker [28 h]; JCB [28 h] | 123,187.5 | 1.3.3.50 | CONS | CONS | ZONE-3 | ROAD-3 | MECH | IRR |
| CON-Z3-UT-IRG-PL-490 |  | Testing and Precommissioning (1843 Lm) | 24d | 2017-05-30 | 2017-07-02 | CON-Z3-UT-IRG-PL-480, CON-Z3-UT-IRG-PL-140 | 37.2d | 0d | Plumber [52 h]; Common Labor / Helper [52 h]; RTR Pipe Crew [52 h]; Driver - Water Tanker [26 h]; Water Tanker [28 h] | 172,462.5 | 1.3.3.50 | CONS | CONS | ZONE-3 | ROAD-3 | MECH | IRR |
|  | 4 | **Irrigation Line - Upvc 200mm dia at Road 5 = 659 Lm** |  | 2017-01-24 | 2017-06-13 |  |  |  |  |  |  |  |  |  |  |  |  |
| CON-Z3-UT-IRG-PL-150 |  | Excavation of Trench | 4.8d | 2017-01-24 | 2017-01-30 | CON-Z3-UT-IRG-PL-100 | 27.8d | 0d | Common Labor / Helper [26 h]; Operator - Excavator [26 h]; Driver - Dump Truck [26 h]; Operator - JCB [26 h]; Excavator [28 h]; Dump Truck [28 h] | 92,390.62 | 1.3.3.50 | CONS | CONS | ZONE-3 | ROAD-5 | MECH | IRR |
| CON-Z3-UT-IRG-PL-160 |  | Compaction and Sand bedding | 8d | 2017-01-29 | 2017-02-06 | CON-Z3-UT-IRG-PL-150 SS+3.2d | 99.4d | 0d | Common Labor / Helper [104 h]; Operator - Loader [26 h]; Driver - Dump Truck [26 h]; Operator - Bobcat [26 h]; Operator - JCB [26 h] | 30,796.87 | 1.3.3.50 | CONS | CONS | ZONE-3 | ROAD-5 | MECH | IRR |
| CON-Z3-UT-IRG-PL-170 |  | Pipe Laying | 12.8d | 2017-02-07 | 2017-02-21 | CON-Z3-UT-IRG-PL-160 | 99.4d | 0d | Plumber [52 h]; Common Labor / Helper [78 h]; RTR Pipe Crew [52 h]; Operator - Mobile Crane [26 h]; Driver - Flat Bed Trailer [26 h]; Mobile Crane ( 25-60 Ton) [28 h]; Flat Bed Trailer [28 h] | 184,781.25 | 1.3.3.50 | CONS | CONS | ZONE-3 | ROAD-5 | MECH | IRR |
| CON-Z3-UT-IRG-PL-180 |  | Installation of Thurst Block | 17.6d | 2017-02-12 | 2017-03-04 | CON-Z3-UT-IRG-PL-170 SS+4d | 99.4d | 47.2d | Steel Fixer [26 h]; Shuttering Carpenter [52 h]; Concrete Mason [52 h]; Common Labor / Helper [52 h]; Driver - Conc. Transit Mixers [26 h]; Operator - Concrete Pump [26 h]; Concrete Transit Mixers [28 h]; Concrete Pump [28 h] | 30,796.87 | 1.3.3.50 | CONS | CONS | ZONE-3 | ROAD-5 | MECH | IRR |
| CON-Z3-UT-IRG-PL-190 |  | Backfilling | 18d | 2017-04-27 | 2017-05-18 | CON-Z3-UT-IRG-PL-170, CON-Z3-UT-IRG-PL-140 FS+20d, CON-Z3-UT-IRG-PL-180 | 52.2d | 15d | Common Labor / Helper [104 h]; Operator - Loader [180 h]; Driver - Dump Truck [180 h]; Operator - Bobcat [180 h]; Operator - Asphalt Compactor / Roller [180 h]; Operator - Roller-Compactor (2~10 Ton) [180 h]; Driver - Water Tanker [180 h]; Operator - JCB [180 h]; Loader [252 h]; Dump Truck [252 h]; Bobcat [252 h]; Roller-Compactor (2~10 Ton) [252 h]; Plate Compactor [252 h]; Vibrators [252 h]; Water Tanker [252 h]; JCB [252 h] | 153,984.37 | 1.3.3.50 | CONS | CONS | ZONE-3 | ROAD-5 | MECH | IRR |
| CON-Z3-UT-IRG-PL-500 |  | Testing and Precommissioning | 6.4d | 2017-06-05 | 2017-06-13 | CON-Z3-UT-IRG-PL-190, CON-Z3-UT-IRG-PL-490 SS+5d | 37.2d | 0d | Plumber [52 h]; Common Labor / Helper [52 h]; RTR Pipe Crew [52 h]; Driver - Water Tanker [64 h]; Water Tanker [89.6 h] | 123,187.5 | 1.3.3.50 | CONS | CONS | ZONE-3 | ROAD-5 | MECH | IRR |

Notes:
- CON-Z3-UT-IRG-PL-030: Expenses: (New Expense Item) 41062.5
- CON-Z3-UT-IRG-PL-040: Expenses: (New Expense Item) 164250
- CON-Z3-UT-IRG-PL-050: Expenses: (New Expense Item) 41062.5
- CON-Z3-UT-IRG-PL-060: Expenses: (New Expense Item) 20531.2
- CON-Z3-UT-IRG-PL-070: Expenses: (New Expense Item) 82125
- CON-Z3-UT-IRG-PL-080: Expenses: (New Expense Item) 20531.2
- CON-Z3-UT-IRG-PL-090: Expenses: (New Expense Item) 102656
- CON-Z3-UT-IRG-PL-480: Expenses: (New Expense Item) 143719
- CON-Z3-UT-IRG-PL-100: Expenses: (New Expense Item) 49275
- CON-Z3-UT-IRG-PL-110: Expenses: (New Expense Item) 24637.5
- CON-Z3-UT-IRG-PL-120: Expenses: (New Expense Item) 98550
- CON-Z3-UT-IRG-PL-130: Expenses: (New Expense Item) 24637.5
- CON-Z3-UT-IRG-PL-140: Expenses: (New Expense Item) 123188
- CON-Z3-UT-IRG-PL-490: Expenses: (New Expense Item) 172462
- CON-Z3-UT-IRG-PL-150: Expenses: (New Expense Item) 92390.6
- CON-Z3-UT-IRG-PL-160: Expenses: (New Expense Item) 30796.9
- CON-Z3-UT-IRG-PL-170: Expenses: (New Expense Item) 184781
- CON-Z3-UT-IRG-PL-180: Expenses: (New Expense Item) 30796.9
- CON-Z3-UT-IRG-PL-190: Expenses: (New Expense Item) 153984
- CON-Z3-UT-IRG-PL-500: Expenses: (New Expense Item) 123188

| ID | WBS | Activity | Duration | Start | Finish | Predecessors | Total float | Free float | Resources | Cost | RPI_P2 - BOQ ITEMS | RPI_P2 - CONSTRUCTION | RPI_P2 - PHASE | RPI_P2 - ZONES | RPI_P2 - AREAS | RPI_P2 - DISCIPLINE / WORK TYPE | RPI_P2 - UTILITY NETWORK |
| --- | --- | --- | --- | --- | --- | --- | --- | --- | --- | --- | --- | --- | --- | --- | --- | --- | --- |
|  | 5 | **Irrigation Line - Upvc 110mm dia at Realm Area = 4221 Lm** |  | 2017-01-30 | 2017-07-15 |  |  |  |  |  |  |  |  |  |  |  |  |
| CON-Z3-UT-IRG-PL-200 |  | Excavation of Trench | 20d | 2017-01-30 | 2017-02-22 | CON-Z3-UT-IRG-PL-150 | 27.8d | 0d | Common Labor / Helper [26 h]; Operator - Excavator [26 h]; Driver - Dump Truck [26 h]; Operator - JCB [26 h]; Excavator [28 h]; Dump Truck [28 h] | 82,125 | 1.3.3.50 | CONS | CONS | ZONE-3 | REALM | MECH | IRR |
| CON-Z3-UT-IRG-PL-210 |  | Compaction and Sand bedding | 20d | 2017-02-02 | 2017-02-26 | CON-Z3-UT-IRG-PL-200 SS+3.2d | 58.2d | 0d | Common Labor / Helper [156 h]; Operator - Loader [39 h]; Driver - Dump Truck [39 h]; Operator - Bobcat [39 h]; Operator - JCB [39 h] | 41,062.5 | 1.3.3.50 | CONS | CONS | ZONE-3 | REALM | MECH | IRR |
| CON-Z3-UT-IRG-PL-220 |  | Pipe Laying | 60d | 2017-02-26 | 2017-05-07 | CON-Z3-UT-IRG-PL-210 | 58.2d | 0d | Plumber [52 h]; Common Labor / Helper [78 h]; RTR Pipe Crew [52 h]; Operator - Mobile Crane [26 h]; Driver - Flat Bed Trailer [26 h]; Mobile Crane ( 25-60 Ton) [28 h]; Flat Bed Trailer [28 h] | 123,187.5 | 1.3.3.50 | CONS | CONS | ZONE-3 | REALM | MECH | IRR |
| CON-Z3-UT-IRG-PL-230 |  | Backfilling | 60d | 2017-03-02 | 2017-05-11 | CON-Z3-UT-IRG-PL-220 SS+4d | 58.2d | 21d | Common Labor / Helper [156 h]; Operator - Loader [39 h]; Driver - Dump Truck [39 h]; Operator - Bobcat [39 h]; Operator - Asphalt Compactor / Roller [39 h]; Operator - Roller-Compactor (2~10 Ton) [39 h]; Driver - Water Tanker [39 h]; Operator - JCB [39 h]; Loader [42 h]; Dump Truck [42 h]; Bobcat [42 h]; Roller-Compactor (2~10 Ton) [42 h]; Plate Compactor [42 h]; Vibrators [42 h]; Water Tanker [42 h]; JCB [42 h] | 61,593.75 | 1.3.3.50 | CONS | CONS | ZONE-3 | REALM | MECH | IRR |
| CON-Z3-UT-IRG-PL-240 |  | Testing and Precommissioning | 30d | 2017-06-05 | 2017-07-15 | CON-Z3-UT-IRG-PL-220, CON-Z3-UT-IRG-PL-230, CON-Z3-UT-IRG-PL-500 SS | 37.2d | 0d | Plumber [52 h]; Common Labor / Helper [52 h]; RTR Pipe Crew [52 h]; Driver - Water Tanker [300 h]; Water Tanker [420 h] | 102,656.25 | 1.3.3.50 | CONS | CONS | ZONE-3 | REALM | MECH | IRR |
|  | 6 | **Irrigation Line - Upvc (32mm-75mm) dia at Realm Area = 4102 Lm** |  | 2017-03-29 | 2017-08-28 |  |  |  |  |  |  |  |  |  |  |  |  |
| CON-Z3-UT-IRG-PL-250 |  | Excavation of Trench | 20d | 2017-03-29 | 2017-04-22 | CON-Z3-UT-IRG-PL-200 FS+30d | 27.8d | 0d | Common Labor / Helper [26 h]; Operator - Excavator [26 h]; Driver - Dump Truck [26 h]; Operator - JCB [26 h]; Excavator [28 h]; Dump Truck [28 h] | 82,125 | 1.3.3.50 | CONS | CONS | ZONE-3 | REALM | MECH | IRR |
| CON-Z3-UT-IRG-PL-260 |  | Compaction and Sand bedding | 20d | 2017-04-02 | 2017-04-25 | CON-Z3-UT-IRG-PL-250 SS+3.2d | 59.8d | 0d | Common Labor / Helper [156 h]; Operator - Loader [39 h]; Driver - Dump Truck [39 h]; Operator - Bobcat [39 h]; Operator - JCB [39 h] | 41,062.5 | 1.3.3.50 | CONS | CONS | ZONE-3 | REALM | MECH | IRR |
| CON-Z3-UT-IRG-PL-270 |  | Pipe Laying | 60d | 2017-04-05 | 2017-06-14 | CON-Z3-UT-IRG-PL-260 SS+2.4d | 59.8d | 0d | Plumber [52 h]; Common Labor / Helper [78 h]; RTR Pipe Crew [52 h]; Operator - Mobile Crane [26 h]; Driver - Flat Bed Trailer [26 h]; Mobile Crane ( 25-60 Ton) [28 h]; Flat Bed Trailer [28 h] | 123,187.5 | 1.3.3.50 | CONS | CONS | ZONE-3 | REALM | MECH | IRR |
| CON-Z3-UT-IRG-PL-280 |  | Backfilling | 60d | 2017-06-14 | 2017-08-28 | CON-Z3-UT-IRG-PL-270 | 59.8d | 22.6d | Common Labor / Helper [156 h]; Operator - Loader [600 h]; Driver - Dump Truck [600 h]; Operator - Bobcat [1200 h]; Operator - Asphalt Compactor / Roller [600 h]; Operator - Roller-Compactor (2~10 Ton) [600 h]; Driver - Water Tanker [600 h]; Operator - JCB [600 h]; Loader [840 h]; Dump Truck [840 h]; Bobcat [1680 h]; Roller-Compactor (2~10 Ton) [840 h]; Plate Compactor [2520 h]; Vibrators [2520 h]; Water Tanker [840 h]; JCB [840 h] | 61,593.75 | 1.3.3.50 | CONS | CONS | ZONE-3 | REALM | MECH | IRR |
| CON-Z3-UT-IRG-PL-290 |  | Testing and Precommissioning | 30d | 2017-07-15 | 2017-08-19 | CON-Z3-UT-IRG-PL-270, CON-Z3-UT-IRG-PL-240, CON-Z3-UT-IRG-PL-280 SS | 37.2d | 9.4d | Plumber [3000 h]; Common Labor / Helper [3000 h]; RTR Pipe Crew [390 h]; Driver - Water Tanker [390 h]; Water Tanker [420 h] | 102,656.25 | 1.3.3.50 | CONS | CONS | ZONE-3 | REALM | MECH | IRR |
|  | 7 | **Irrigation Line - Upvc (25mm) dia at Realm Area = 4092 Lm** |  | 2017-05-01 | 2017-08-30 |  |  |  |  |  |  |  |  |  |  |  |  |
| CON-Z3-UT-IRG-PL-300 |  | Excavation of Trench | 21d | 2017-05-01 | 2017-05-25 | CON-Z3-UT-IRG-PL-250 FS+8d | 27.8d | 0d | Common Labor / Helper [39 h]; Operator - Excavator [39 h]; Driver - Dump Truck [39 h]; Operator - JCB [39 h]; Excavator [42 h]; Dump Truck [42 h] | 82,125 | 1.3.3.50 | CONS | CONS | ZONE-3 | REALM | MECH | IRR |
| CON-Z3-UT-IRG-PL-310 |  | Compaction and Sand bedding | 20d | 2017-05-04 | 2017-05-28 | CON-Z3-UT-IRG-PL-300 SS+3.2d | 27.8d | 0d | Common Labor / Helper [208 h]; Operator - Loader [52 h]; Driver - Dump Truck [52 h]; Operator - Bobcat [52 h]; Operator - JCB [52 h] | 41,062.5 | 1.3.3.50 | CONS | CONS | ZONE-3 | REALM | MECH | IRR |
| CON-Z3-UT-IRG-PL-320 |  | Pipe Laying | 60d | 2017-05-08 | 2017-07-22 | CON-Z3-UT-IRG-PL-310 SS+2.4d | 27.8d | 0d | Plumber [78 h]; Common Labor / Helper [117 h]; RTR Pipe Crew [78 h]; Operator - Mobile Crane [39 h]; Driver - Flat Bed Trailer [39 h]; Mobile Crane ( 25-60 Ton) [42 h]; Flat Bed Trailer [42 h] | 123,187.5 | 1.3.3.50 | CONS | CONS | ZONE-3 | REALM | MECH | IRR |
| CON-Z3-UT-IRG-PL-330 |  | Backfilling | 60d | 2017-05-13 | 2017-07-26 | CON-Z3-UT-IRG-PL-320 SS+4d | 27.8d | 0d | Dump Truck [42 h]; Bobcat [42 h]; Roller-Compactor (2~10 Ton) [42 h]; Plate Compactor [42 h]; Vibrators [42 h]; Water Tanker [42 h]; JCB [42 h]; Common Labor / Helper [156 h]; Operator - Loader [39 h]; Driver - Dump Truck [39 h]; Operator - Bobcat [39 h]; Operator - Asphalt Compactor / Roller [39 h]; Operator - Roller-Compactor (2~10 Ton) [39 h]; Driver - Water Tanker [39 h]; Operator - JCB [39 h]; Loader [42 h] | 61,593.75 | 1.3.3.50 | CONS | CONS | ZONE-3 | REALM | MECH | IRR |
| CON-Z3-UT-IRG-PL-340 |  | Testing and Precommissioning | 30d | 2017-07-26 | 2017-08-30 | CON-Z3-UT-IRG-PL-330, CON-Z3-UT-IRG-PL-290 SS, CON-Z3-UT-IRG-PL-320 | 27.8d | 0d | Plumber [2340 h]; Common Labor / Helper [2340 h]; RTR Pipe Crew [390 h]; Driver - Water Tanker [390 h]; Water Tanker [420 h] | 102,656.25 | 1.3.3.50 | CONS | CONS | ZONE-3 | REALM | MECH | IRR |
|  | 8 | **Irrigation Equipments** |  | 2017-07-26 | 2017-08-23 |  |  |  |  |  |  |  |  |  |  |  |  |
| CON-Z3-UT-IRG-PL-350 |  | Installation of Rainbird Solenoid Valves, 100-PEB (Remote Control Valves for Bubbler and Drip Emitter System) | 8d | 2017-07-26 | 2017-08-05 | CON-Z3-UT-IRG-PL-240, CON-Z3-UT-IRG-PL-340 SS, CON-Z3-UT-IRG-PL-290 SS | 39.8d | 0d | Common Labor / Helper [800 h]; Soft Landscaping Crew [160 h]; Specialist Works Crew [160 h] | 82,125 | 1.3.3.50 | CONS | CONS | ZONE-3 |  | MECH | IRR |
| CON-Z3-UT-IRG-PL-510 |  | Installation of Burried Gate Valves | 16d | 2017-07-26 | 2017-08-14 | CON-Z3-UT-IRG-PL-410 SS, CON-Z3-UT-IRG-PL-340 SS | 51.8d | 12d | Common Labor / Helper [320 h]; Soft Landscaping Crew [160 h]; Specialist Works Crew [160 h] | 41,062.5 | 1.3.3.50 | CONS | CONS | ZONE-3 |  | MECH | IRR |
| CON-Z3-UT-IRG-PL-360 |  | Installation of Rainbird Solenoid Valve, 150-PEB (Remote Control Valves for Bubbler System) | 8d | 2017-07-29 | 2017-08-07 | CON-Z3-UT-IRG-PL-350 SS+2.4d | 40.8d | 0d | Common Labor / Helper [400 h]; Soft Landscaping Crew [80 h]; Specialist Works Crew [80 h] | 82,125 | 1.3.3.50 | CONS | CONS | ZONE-3 |  | MECH | IRR |
| CON-Z3-UT-IRG-PL-370 |  | Installation of Rainbird Solenoid Valve, 200-PEB (Remote Control Valves for Sprinkler System) | 8d | 2017-08-01 | 2017-08-09 | CON-Z3-UT-IRG-PL-360 SS+2.4d | 40.8d | 0d | Common Labor / Helper [520 h]; Soft Landscaping Crew [104 h]; Specialist Works Crew [104 h] | 82,125 | 1.3.3.50 | CONS | CONS | ZONE-3 |  | MECH | IRR |
| CON-Z3-UT-IRG-PL-380 |  | Installation of Rainbird PRS-Dial with Pressure Indicating Carting | 8d | 2017-08-03 | 2017-08-13 | CON-Z3-UT-IRG-PL-370 SS+2.4d | 40.8d | 0d | Common Labor / Helper [416 h]; Soft Landscaping Crew [104 h]; Specialist Works Crew [104 h] | 41,062.5 | 1.3.3.50 | CONS | CONS | ZONE-3 |  | MECH | IRR |
| CON-Z3-UT-IRG-PL-390 |  | Installation of Rainbird XCZ-PRB-100-com series solenoid valve assembly | 12d | 2017-08-06 | 2017-08-20 | CON-Z3-UT-IRG-PL-380 SS+2.4d | 40.8d | 0d | Common Labor / Helper [780 h]; Soft Landscaping Crew [156 h]; Specialist Works Crew [156 h] | 41,062.5 | 1.3.3.50 | CONS | CONS | ZONE-3 |  | MECH | IRR |
| CON-Z3-UT-IRG-PL-400 |  | Installation of Rainbird XCZ-PRB-150-com series solenoid valve assembly | 12d | 2017-08-09 | 2017-08-23 | CON-Z3-UT-IRG-PL-390 SS+2.4d | 40.8d | 6d | Common Labor / Helper [780 h]; Soft Landscaping Crew [156 h]; Specialist Works Crew [156 h] | 41,062.5 | 1.3.3.50 | CONS | CONS | ZONE-3 |  | MECH | IRR |

Notes:
- CON-Z3-UT-IRG-PL-200: Expenses: (New Expense Item) 82125
- CON-Z3-UT-IRG-PL-210: Expenses: (New Expense Item) 41062.5
- CON-Z3-UT-IRG-PL-220: Expenses: (New Expense Item) 123188
- CON-Z3-UT-IRG-PL-230: Expenses: (New Expense Item) 61593.8
- CON-Z3-UT-IRG-PL-240: Expenses: (New Expense Item) 102656
- CON-Z3-UT-IRG-PL-250: Expenses: (New Expense Item) 82125
- CON-Z3-UT-IRG-PL-260: Expenses: (New Expense Item) 41062.5
- CON-Z3-UT-IRG-PL-270: Expenses: (New Expense Item) 123188
- CON-Z3-UT-IRG-PL-280: Expenses: (New Expense Item) 61593.8
- CON-Z3-UT-IRG-PL-290: Expenses: (New Expense Item) 102656
- CON-Z3-UT-IRG-PL-300: Expenses: (New Expense Item) 82125
- CON-Z3-UT-IRG-PL-310: Expenses: (New Expense Item) 41062.5
- CON-Z3-UT-IRG-PL-320: Expenses: (New Expense Item) 123188
- CON-Z3-UT-IRG-PL-330: Expenses: (New Expense Item) 61593.8
- CON-Z3-UT-IRG-PL-340: Expenses: (New Expense Item) 102656
- CON-Z3-UT-IRG-PL-350: Expenses: (New Expense Item) 82125
- CON-Z3-UT-IRG-PL-510: Expenses: (New Expense Item) 41062.5
- CON-Z3-UT-IRG-PL-360: Expenses: (New Expense Item) 82125
- CON-Z3-UT-IRG-PL-370: Expenses: (New Expense Item) 82125
- CON-Z3-UT-IRG-PL-380: Expenses: (New Expense Item) 41062.5
- CON-Z3-UT-IRG-PL-390: Expenses: (New Expense Item) 41062.5
- CON-Z3-UT-IRG-PL-400: Expenses: (New Expense Item) 41062.5

| ID | WBS | Activity | Duration | Start | Finish | Predecessors | Total float | Free float | Resources | Cost | RPI_P2 - BOQ ITEMS | RPI_P2 - CONSTRUCTION | RPI_P2 - PHASE | RPI_P2 - ZONES | RPI_P2 - DISCIPLINE / WORK TYPE | RPI_P2 - UTILITY NETWORK | Activity Wt% | Weight % | Cost Wt | RPI - PHASE | RPI - CONSTRUCTION | RPI - ZONES | RPI - UTILITY NETWORKS | RPI - TYPE OF WORK | RPI_P2 - AREAS |
| --- | --- | --- | --- | --- | --- | --- | --- | --- | --- | --- | --- | --- | --- | --- | --- | --- | --- | --- | --- | --- | --- | --- | --- | --- | --- |
|  | 9 | **Electrical Instalaltion for Irrigation System** |  | 2017-05-25 | 2017-08-22 |  |  |  |  |  |  |  |  |  |  |  |  |  |  |  |  |  |  |  |  |
| CON-Z3-UT-IRG-PL-410 |  | Excavation of Trench | 24d | 2017-05-25 | 2017-06-22 | CON-Z3-UT-IRG-PL-300 | 40.4d | 0d | Common Labor / Helper [26 h]; Operator - Excavator [26 h]; Driver - Dump Truck [26 h]; Operator - JCB [26 h]; Excavator [28 h]; Dump Truck [28 h] | 20,531.25 | 1.3.3.50 | CONS | CONS | ZONE-3 | ELEC | IRR |  |  |  |  |  |  |  |  |  |
| CON-Z3-UT-IRG-PL-420 |  | Sand Bedding | 12d | 2017-06-22 | 2017-07-11 | CON-Z3-UT-IRG-PL-410 | 42.4d | 0d | Common Labor / Helper [104 h]; Operator - Loader [26 h]; Driver - Dump Truck [26 h]; Operator - Bobcat [26 h]; Operator - JCB [26 h]; Loader [28 h]; Dump Truck [28 h]; Bobcat [28 h]; JCB [28 h] | 10,265.63 | 1.3.3.50 | CONS | CONS | ZONE-3 | ELEC | IRR |  |  |  |  |  |  |  |  |  |
| CON-Z3-UT-IRG-PL-430 |  | Instalaltion of direct burial Solid Irrigation Wires | 8d | 2017-07-11 | 2017-07-20 | CON-Z3-UT-IRG-PL-420, PR-MT-Z1-LC-08-0080, PR-Z3-UT-PW-151-0080 | 42.4d | 0d | Electrician [320 h]; Common Labor / Helper [52 h] | 41,062.5 | 1.3.3.50 | CONS | CONS | ZONE-3 | ELEC | IRR |  |  |  |  |  |  |  |  |  |
| CON-Z3-UT-IRG-PL-440 |  | Sandfilling,Red Tiles and Warning Tape | 12d | 2017-07-20 | 2017-08-03 | PR-Z3-UT-PW-147-0080, CON-Z3-UT-IRG-PL-430 | 42.4d | 0d | Common Labor / Helper [78 h]; Block Mason [120 h]; Tiling Crew [120 h] | 51,328.12 | 1.3.3.50 | CONS | CONS | ZONE-3 | ELEC | IRR |  |  |  |  |  |  |  |  |  |
| CON-Z3-UT-IRG-PL-450 |  | Backfilling of Trench | 16d | 2017-08-03 | 2017-08-22 | CON-Z3-UT-IRG-PL-440 | 42.4d | 0d | Common Labor / Helper [1248 h]; Operator - Loader [208 h]; Driver - Dump Truck [208 h]; Operator - Bobcat [208 h]; Operator - Asphalt Compactor / Roller [208 h]; Operator - Roller-Compactor (2~10 Ton) [208 h]; Driver - Water Tanker [208 h]; Operator - JCB [208 h]; Loader [224 h]; Dump Truck [224 h]; Bobcat [224 h]; Roller-Compactor (2~10 Ton) [224 h]; Plate Compactor [224 h]; Vibrators [224 h]; Water Tanker [224 h]; JCB [224 h] | 20,531.25 | 1.3.3.50 | CONS | CONS | ZONE-3 | ELEC | IRR |  |  |  |  |  |  |  |  |  |
| CON-Z3-UT-IRG-PL-460 |  | Installation of Solar Power Irrigation Controller | 8d | 2017-08-03 | 2017-08-13 | CON-Z3-UT-IRG-PL-450 SS | 42.4d | 0d | Electrician [624 h] | 41,062.5 | 1.3.3.50 | CONS | CONS | ZONE-3 | ELEC | IRR |  |  |  |  |  |  |  |  |  |
| CON-Z3-UT-IRG-PL-470 |  | Instalaltion of Junction Boxes | 7d | 2017-08-13 | 2017-08-21 | CON-Z3-UT-IRG-PL-460 | 42.4d | 2.6d | Electrician [546 h] | 20,531.25 | 1.3.3.50 | CONS | CONS | ZONE-3 | ELEC | IRR |  |  |  |  |  |  |  |  |  |
|  | 10 | **Tie in Connections With Existing KAUST Utility** |  | 2017-08-06 | 2017-08-30 |  |  |  |  |  |  |  |  |  |  |  |  |  |  |  |  |  |  |  |  |
| CON-Z3-UT-IRG-GE-010 |  | Extension Existing KAUST STP Interface With Pipe near VB#5 in Zone 2A near CUP Area. | 8d | 2017-08-06 | 2017-08-15 | CON-Z3-UT-IRG-PL-340 SS+9d | 27.8d | 0d | Plumber [52 h]; Common Labor / Helper [52 h] | 51,328.12 | 1.3.3.50 | CONS | CONS | ZONE-3 | MECH | IRR |  |  |  |  |  |  |  |  |  |
| CON-Z3-UT-IRG-GE-020 |  | Rd-5 Crossing Connections | 8d | 2017-08-08 | 2017-08-17 | CON-Z3-UT-IRG-GE-010 SS+2d | 27.8d | 0d | Plumber [52 h]; Common Labor / Helper [52 h] | 51,328.12 | 1.3.3.50 | CONS | CONS | ZONE-3 | MECH | IRR |  |  |  |  |  |  |  |  |  |
| CON-Z3-UT-IRG-GE-030 |  | Rd-4 Crossing Irrigation Line | 8d | 2017-08-17 | 2017-08-27 | CON-Z3-UT-IRG-GE-020 | 27.8d | 0d | Plumber [52 h]; Common Labor / Helper [52 h] | 51,328.12 | 1.3.3.50 | CONS | CONS | ZONE-3 | MECH | IRR |  |  |  |  |  |  |  |  |  |
| CON-Z3-UT-IRG-GE-050 |  | Completion of SOLAR Irrigation Controller System Iterface With Existing KAUST Control Room.(IT & Equipment) | 9d | 2017-08-20 | 2017-08-30 | CON-Z3-UT-IRG-GE-030 SS+2d | 27.8d | 0d | Plumber [52 h]; Common Labor / Helper [52 h] | 51,328.12 | 1.3.3.50 | CONS | CONS | ZONE-3 | MECH | IRR |  |  |  |  |  |  |  |  |  |
|  | 6 | **Storm Water Drainage System** |  | 2016-10-29 | 2017-10-02 |  |  |  |  |  |  |  |  |  |  |  |  |  |  |  |  |  |  |  |  |
|  | 11 | **Storm Water Ditch** |  | 2016-10-29 | 2017-08-14 |  |  |  |  |  |  |  |  |  |  |  |  |  |  |  |  |  |  |  |  |
|  | 1 | **Storm Water Ditch D-5 at Road A (3.0m Width -Type - I)** |  | 2016-10-29 | 2017-03-11 |  |  |  |  |  |  |  |  |  |  |  |  |  |  |  |  |  |  |  |  |
| CON-Z3-UTI-SD-0010 |  | Excavation | 4d | 2016-10-29 | 2016-11-02 | CON-CON-CON-CON-0010 FS+65d | 34.8d | 0d | Common Labor / Helper [600 h]; Excavator [112 h]; Operator - Excavator [80 h]; JCB [80 h]; Operator - JCB [80 h] | 31,331.33 | 1.3.3.60 | CONS | CONS | ZONE-3 | CIVIL | STORM | 0 | 0 | 0.0099611056 | 6 | RPI - CONS | Z1 | STORM | CIVIL | ROAD-A |
| CON-Z3-UTI-SD-0020 |  | Backfilling / Compaction, Bed Preparation, Polyethylene Sheet Vapor Barrier | 6.4d | 2016-11-06 | 2016-11-13 | PR-Z3-CW-CW-26-0080, GE-MS-ENG-ENG-0040, CON-Z3-UTI-SD-0010, CON-Z3-UTI-SD-0010 SS+4d | 165.6d | 0d | Common Labor / Helper [32 h]; Driver - Dump Truck [32 h]; Operator - Bobcat [32 h]; Operator - Roller-Compactor (2~10 Ton) [32 h]; Driver - Water Tanker [32 h]; Operator - JCB [32 h]; Bobcat [268.8 h]; Plate Compactor [32 h]; Vibrators [32 h]; Water Tanker [32 h]; JCB [32 h] | 52,218.89 | 1.3.3.60 | CONS | CONS | ZONE-3 | CIVIL | STORM | 0 | 0 | 0.0199222112 | 6 | RPI - CONS | Z1 | STORM | CIVIL | ROAD-A |
| CON-Z3-UTI-SD-0030 |  | Welded Wire Mesh and Concrete Works | 15d | 2016-11-08 | 2016-11-24 | CON-Z3-UTI-SD-0020 SS+1.6d | 165.6d | 70.4d | Shuttering Carpenter [975 h]; Concrete Mason [780 h]; Common Labor / Helper [1560 h]; Finishing Work Crew [390 h]; Driver - Conc. Transit Mixers [195 h]; Operator - Concrete Pump [195 h]; Concrete Transit Mixers [210 h]; Concrete Pump [210 h] | 83,550.22 | 1.3.3.60 | CONS | CONS | ZONE-3 | CIVIL | STORM | 0 | 0 | 0.0597666337 | 6 | RPI - CONS | Z1 | STORM | CIVIL | ROAD-A |
| CON-Z3-UTI-SD-0040 |  | Bitumen Coating & Backfilling | 20d | 2017-02-15 | 2017-03-11 | CON-Z3-UTI-SD-0030, PR-Z3-CW-CW-23-0080 | 95.2d | 0d | Common Labor / Helper [52 h]; Painter [52 h]; Operator - Bobcat [26 h]; Operator - Roller-Compactor (2~10 Ton) [26 h]; Driver - Water Tanker [26 h]; Operator - JCB [26 h]; Bobcat [28 h]; Roller-Compactor (2~10 Ton) [28 h]; Plate Compactor [28 h]; Vibrators [28 h]; JCB [28 h] | 41,775.11 | 1.3.3.60 | CONS | CONS | ZONE-3 | CIVIL | STORM | 0 | 0 | 0.0099611056 | 6 | RPI - CONS | Z1 | STORM | CIVIL | ROAD-A |
|  | 2 | **Storm Water Ditch D-6 at Road A (3.0m Width -Type - I)** |  | 2016-11-02 | 2017-03-27 |  |  |  |  |  |  |  |  |  |  |  |  |  |  |  |  |  |  |  |  |
| CON-Z3-UTI-SD-0050 |  | Excavation | 3.2d | 2016-11-02 | 2016-11-06 | CON-Z3-UTI-SD-0010 | 129d | 0d | Common Labor / Helper [16 h]; Excavator [16 h]; Operator - Excavator [16 h] | 15,665.67 | 1.3.3.60 | CONS | CONS | ZONE-3 | CIVIL | STORM | 0 | 0 | 0.0099611056 | 6 | RPI - CONS | Z1 | STORM | CIVIL | ROAD-A |
| CON-Z3-UTI-SD-0060 |  | Backfilling / Compaction, Bed Preparation, Polyethylene Sheet Vapor Barrier | 5.6d | 2016-11-07 | 2016-11-13 | CON-Z3-UTI-SD-0050 SS+4d, CON-Z3-UTI-SD-0050 | 180.8d | 0d | Loader [28 h]; Dump Truck [28 h]; Bobcat [156.8 h]; Roller-Compactor (2~10 Ton) [28 h]; Plate Compactor [28 h]; Vibrators [28 h]; Water Tanker [28 h]; JCB [28 h]; Common Labor / Helper [28 h]; Painter [145.6 h]; Water Proofing Crew [28 h]; Operator - Loader [28 h]; Driver - Dump Truck [28 h]; Operator - Bobcat [28 h]; Operator - Roller-Compactor (2~10 Ton) [28 h]; Driver - Water Tanker [28 h] | 26,109.44 | 1.3.3.60 | CONS | CONS | ZONE-3 | CIVIL | STORM | 0 | 0 | 0.0199222112 | 6 | RPI - CONS | Z1 | STORM | CIVIL | ROAD-A |
| CON-Z3-UTI-SD-0070 |  | Welded Wire Mesh and Concrete Works | 15d | 2016-11-08 | 2016-11-26 | CON-Z3-UTI-SD-0060 SS+1.6d | 180.8d | 85.6d | Shuttering Carpenter [975 h]; Concrete Mason [780 h]; Common Labor / Helper [1560 h]; Finishing Work Crew [195 h]; Driver - Conc. Transit Mixers [195 h]; Operator - Concrete Pump [195 h]; Concrete Transit Mixers [210 h]; Concrete Pump [210 h] | 41,775.11 | 1.3.3.60 | CONS | CONS | ZONE-3 | CIVIL | STORM | 0 | 0 | 0.0597666337 | 6 | RPI - CONS | Z1 | STORM | CIVIL | ROAD-A |
| CON-Z3-UTI-SD-0080 |  | Bitumen Coating & Backfilling | 14.4d | 2017-03-11 | 2017-03-27 | CON-Z3-UTI-SD-0040, CON-Z3-UTI-SD-0070 FS+4d | 95.2d | 0d | Common Labor / Helper [52 h]; Painter [52 h]; Operator - Bobcat [26 h]; Operator - Roller-Compactor (2~10 Ton) [26 h]; Driver - Water Tanker [26 h]; Operator - JCB [26 h]; Bobcat [28 h]; Plate Compactor [28 h]; Vibrators [28 h]; Water Tanker [28 h]; JCB [28 h] | 20,887.56 | 1.3.3.60 | CONS | CONS | ZONE-3 | CIVIL | STORM | 0 | 0 | 0.0099611056 | 6 | RPI - CONS | Z1 | STORM | CIVIL | ROAD-A |

Notes:
- CON-Z3-UT-IRG-PL-410: Expenses: (New Expense Item) 20531.2
- CON-Z3-UT-IRG-PL-420: Expenses: (New Expense Item) 10265.6
- CON-Z3-UT-IRG-PL-430: Expenses: (New Expense Item) 41062.5
- CON-Z3-UT-IRG-PL-440: Expenses: (New Expense Item) 51328.1
- CON-Z3-UT-IRG-PL-450: Expenses: (New Expense Item) 20531.2
- CON-Z3-UT-IRG-PL-460: Expenses: (New Expense Item) 41062.5
- CON-Z3-UT-IRG-PL-470: Expenses: (New Expense Item) 20531.2
- CON-Z3-UT-IRG-GE-010: Expenses: (New Expense Item) 51328.1
- CON-Z3-UT-IRG-GE-020: Expenses: (New Expense Item) 51328.1
- CON-Z3-UT-IRG-GE-030: Expenses: (New Expense Item) 51328.1
- CON-Z3-UT-IRG-GE-050: Expenses: (New Expense Item) 51328.1
- CON-Z3-UTI-SD-0010: Expenses: (New Expense Item) 31331.3
- CON-Z3-UTI-SD-0020: Expenses: (New Expense Item) 52218.9
- CON-Z3-UTI-SD-0030: Expenses: (New Expense Item) 83550.2
- CON-Z3-UTI-SD-0040: Expenses: (New Expense Item) 41775.1
- CON-Z3-UTI-SD-0050: Expenses: (New Expense Item) 15665.7
- CON-Z3-UTI-SD-0060: Expenses: (New Expense Item) 26109.4
- CON-Z3-UTI-SD-0070: Expenses: (New Expense Item) 41775.1
- CON-Z3-UTI-SD-0080: Expenses: (New Expense Item) 20887.6

| ID | WBS | Activity | Duration | Start | Finish | Predecessors | Total float | Free float | Resources | Cost | Activity Wt% | Weight % | Cost Wt | RPI - PHASE | RPI - CONSTRUCTION | RPI - ZONES | RPI - UTILITY NETWORKS | RPI - TYPE OF WORK | RPI_P2 - BOQ ITEMS | RPI_P2 - CONSTRUCTION | RPI_P2 - PHASE | RPI_P2 - ZONES | RPI_P2 - AREAS | RPI_P2 - DISCIPLINE / WORK TYPE | RPI_P2 - UTILITY NETWORK |
| --- | --- | --- | --- | --- | --- | --- | --- | --- | --- | --- | --- | --- | --- | --- | --- | --- | --- | --- | --- | --- | --- | --- | --- | --- | --- |
|  | 3 | **Storm Water Ditch D-8 at Road 2 (2.5m Width -Type - II)** |  | 2016-11-06 | 2017-05-17 |  |  |  |  |  |  |  |  |  |  |  |  |  |  |  |  |  |  |  |  |
| CON-Z3-UTI-SD-0090 |  | Excavation | 9.6d | 2016-11-06 | 2016-11-16 | CON-Z3-UTI-SD-0050 | 129d | 0d | Common Labor / Helper [48 h]; Excavator [268.8 h]; Operator - Excavator [192 h] | 15,665.67 | 0 | 0 | 0.0099611056 | 6 | RPI - CONS | Z1 | STORM | CIVIL | 1.3.3.60 | CONS | CONS | ZONE-3 | ROAD-2 | CIVIL | STORM |
| CON-Z3-UTI-SD-0100 |  | Backfilling / Compaction, Bed Preparation, Polyethylene Sheet Vapor Barrier | 16d | 2016-11-17 | 2016-12-05 | CON-Z3-UTI-SD-0090, CON-Z3-UTI-SD-0090 SS+4d | 175.4d | 0d | Common Labor / Helper [80 h]; Painter [416 h]; Water Proofing Crew [208 h]; Operator - Loader [208 h]; Driver - Dump Truck [320 h]; Operator - Bobcat [208 h]; Operator - Roller-Compactor (2~10 Ton) [208 h]; Driver - Water Tanker [208 h]; Loader [224 h]; Dump Truck [448 h]; Bobcat [224 h]; Roller-Compactor (2~10 Ton) [224 h]; Plate Compactor [224 h]; Vibrators [224 h]; Water Tanker [224 h]; JCB [448 h]; Operator - JCB [320 h] | 26,109.44 | 0 | 0 | 0.0199222112 | 6 | RPI - CONS | Z1 | STORM | CIVIL | 1.3.3.60 | CONS | CONS | ZONE-3 | ROAD-2 | CIVIL | STORM |
| CON-Z3-UTI-SD-0110 |  | Welded Wire Mesh and Concrete Works | 30d | 2016-11-19 | 2016-12-24 | CON-Z3-UTI-SD-0100 SS+1.6d | 175.4d | 80.2d | Shuttering Carpenter [1560 h]; Concrete Mason [1560 h]; Common Labor / Helper [2340 h]; Finishing Work Crew [390 h]; Driver - Conc. Transit Mixers [390 h]; Operator - Concrete Pump [390 h]; Concrete Transit Mixers [420 h]; Concrete Pump [420 h] | 41,775.11 | 0 | 0 | 0.0597666337 | 6 | RPI - CONS | Z1 | STORM | CIVIL | 1.3.3.60 | CONS | CONS | ZONE-3 | ROAD-2 | CIVIL | STORM |
| CON-Z3-UTI-SD-0120 |  | Bitumen Coating & Backfilling | 44d | 2017-03-27 | 2017-05-17 | CON-Z3-UTI-SD-0110, CON-Z3-UTI-SD-0080 | 95.2d | 0d | Common Labor / Helper [52 h]; Painter [52 h]; Operator - Bobcat [26 h]; Operator - Roller-Compactor (2~10 Ton) [26 h]; Driver - Water Tanker [26 h]; Operator - JCB [26 h]; Bobcat [28 h]; Plate Compactor [28 h]; Vibrators [28 h]; Water Tanker [28 h]; JCB [28 h] | 20,887.56 | 0 | 0 | 0.0099611056 | 6 | RPI - CONS | Z1 | STORM | CIVIL | 1.3.3.60 | CONS | CONS | ZONE-3 | ROAD-2 | CIVIL | STORM |
|  | 4 | **Storm Water Ditch D-9 at Road 3 (2m Width -Type - I)** |  | 2016-11-17 | 2017-08-14 |  |  |  |  |  |  |  |  |  |  |  |  |  |  |  |  |  |  |  |  |
| CON-Z3-UTI-SD-0130 |  | Excavation | 19.2d | 2016-11-17 | 2016-12-10 | CON-Z3-UTI-SD-0090 | 129d | 0d | Common Labor / Helper [26 h] | 46,997 | 0 | 0 | 0.0099611056 | 6 | RPI - CONS | Z1 | STORM | CIVIL | 1.3.3.60 | CONS | CONS | ZONE-3 | ROAD-3 | CIVIL | STORM |
| CON-Z3-UTI-SD-0140 |  | Backfilling / Compaction, Bed Preparation, Polyethylene Sheet Vapor Barrier | 32d | 2016-12-10 | 2017-01-16 | CON-Z3-UTI-SD-0130, CON-Z3-UTI-SD-0130 SS+4d | 160.2d | 0d | Common Labor / Helper [104 h]; Painter [52 h]; Water Proofing Crew [52 h]; Operator - Loader [26 h]; Driver - Dump Truck [26 h]; Operator - Bobcat [26 h]; Operator - Roller-Compactor (2~10 Ton) [26 h]; Driver - Water Tanker [26 h]; Loader [28 h]; Dump Truck [28 h]; Bobcat [28 h]; Roller-Compactor (2~10 Ton) [28 h]; Plate Compactor [28 h]; Vibrators [28 h]; Water Tanker [28 h]; JCB [28 h] | 78,328.34 | 0 | 0 | 0.0199222112 | 6 | RPI - CONS | Z1 | STORM | CIVIL | 1.3.3.60 | CONS | CONS | ZONE-3 | ROAD-3 | CIVIL | STORM |
| CON-Z3-UTI-SD-0150 |  | Welded Wire Mesh and Concrete Works | 60d | 2016-12-11 | 2017-02-19 | CON-Z3-UTI-SD-0140 SS+1.6d | 160.2d | 65d | Shuttering Carpenter [78 h]; Concrete Mason [78 h]; Common Labor / Helper [104 h]; Finishing Work Crew [52 h]; Driver - Conc. Transit Mixers [26 h]; Operator - Concrete Pump [26 h]; Concrete Transit Mixers [28 h]; Concrete Pump [28 h] | 125,325.34 | 0 | 0 | 0.0597666337 | 6 | RPI - CONS | Z1 | STORM | CIVIL | 1.3.3.60 | CONS | CONS | ZONE-3 | ROAD-3 | CIVIL | STORM |
| CON-Z3-UTI-SD-0160 |  | Bitumen Coating & Backfilling | 72d | 2017-05-17 | 2017-08-14 | CON-Z3-UTI-SD-0150 FS+10d, CON-Z3-UTI-SD-0120 | 95.2d | 0d | Common Labor / Helper [52 h]; Painter [52 h]; Operator - Bobcat [26 h]; Operator - Roller-Compactor (2~10 Ton) [26 h]; Driver - Water Tanker [26 h]; Operator - JCB [26 h]; Bobcat [28 h]; Plate Compactor [28 h]; Vibrators [28 h]; Water Tanker [28 h]; JCB [28 h] | 62,662.67 | 0 | 0 | 0.0099611056 | 6 | RPI - CONS | Z1 | STORM | CIVIL | 1.3.3.60 | CONS | CONS | ZONE-3 | ROAD-3 | CIVIL | STORM |
|  | 5 | **Storm Water Ditch D-10 at Road 2 and Road 4 (2.5m Width -Type - I)** |  | 2016-12-10 | 2017-07-16 |  |  |  |  |  |  |  |  |  |  |  |  |  |  |  |  |  |  |  |  |
| CON-Z3-UTI-SD-0170 |  | Excavation | 11.2d | 2016-12-10 | 2016-12-22 | CON-Z3-UTI-SD-0130 | 129d | 0d | Common Labor / Helper [26 h] | 46,997 | 0 | 0 | 0.0099611056 | 6 | RPI - CONS | Z1 | STORM | CIVIL | 1.3.3.60 | CONS | CONS | ZONE-3 | ROAD-2 | CIVIL | STORM |
| CON-Z3-UTI-SD-0180 |  | Backfilling / Compaction, Bed Preparation, Polyethylene Sheet Vapor Barrier | 17.6d | 2016-12-22 | 2017-01-11 | CON-Z3-UTI-SD-0170, CON-Z3-UTI-SD-0170 SS+4d | 188.6d | 0d | Common Labor / Helper [104 h]; Painter [52 h]; Water Proofing Crew [52 h]; Operator - Loader [26 h]; Driver - Dump Truck [26 h]; Operator - Bobcat [26 h]; Operator - Roller-Compactor (2~10 Ton) [26 h]; Driver - Water Tanker [26 h]; Loader [28 h]; Dump Truck [28 h]; Bobcat [28 h]; Roller-Compactor (2~10 Ton) [28 h]; Plate Compactor [28 h]; Vibrators [28 h]; Water Tanker [28 h]; JCB [28 h] | 78,328.34 | 0 | 0 | 0.0199222112 | 6 | RPI - CONS | Z1 | STORM | CIVIL | 1.3.3.60 | CONS | CONS | ZONE-3 | ROAD-2 | CIVIL | STORM |
| CON-Z3-UTI-SD-0190 |  | Welded Wire Mesh and Concrete Works | 30.4d | 2016-12-25 | 2017-01-29 | CON-Z3-UTI-SD-0180 SS+1.6d | 188.6d | 93.4d | Shuttering Carpenter [78 h]; Concrete Mason [78 h]; Common Labor / Helper [104 h]; Finishing Work Crew [52 h]; Driver - Conc. Transit Mixers [26 h]; Operator - Concrete Pump [26 h]; Concrete Transit Mixers [28 h]; Concrete Pump [28 h] | 125,325.34 | 0 | 0 | 0.0597666337 | 6 | RPI - CONS | Z1 | STORM | CIVIL | 1.3.3.60 | CONS | CONS | ZONE-3 | ROAD-2 | CIVIL | STORM |
| CON-Z3-UTI-SD-0200 |  | Bitumen Coating & Backfilling | 46.4d | 2017-05-17 | 2017-07-16 | CON-Z3-UTI-SD-0190, CON-Z3-UTI-SD-0160 SS | 95.2d | 0d | Water Tanker [28 h]; JCB [28 h]; Common Labor / Helper [52 h]; Painter [52 h]; Operator - Bobcat [26 h]; Operator - Roller-Compactor (2~10 Ton) [26 h]; Driver - Water Tanker [26 h]; Operator - JCB [26 h]; Bobcat [28 h]; Plate Compactor [28 h]; Vibrators [28 h] | 62,662.67 | 0 | 0 | 0.0099611056 | 6 | RPI - CONS | Z1 | STORM | CIVIL | 1.3.3.60 | CONS | CONS | ZONE-3 | ROAD-2 | CIVIL | STORM |
|  | 6 | **Storm Water Ditch D-11 at Road 3 and Road B (2m Width -Type - II)** |  | 2016-12-22 | 2017-07-17 |  |  |  |  |  |  |  |  |  |  |  |  |  |  |  |  |  |  |  |  |
| CON-Z3-UTI-SD-200 |  | Excavation | 12d | 2016-12-22 | 2017-01-05 | CON-Z3-UTI-SD-0170 | 129d | 0d | Common Labor / Helper [26 h] | 46,997 | 0 | 0 | 0.0099611056 | 6 | RPI - CONS | Z1 | STORM | CIVIL | 1.3.3.60 | CONS | CONS | ZONE-3 | ROAD-3 | CIVIL | STORM |
| CON-Z3-UTI-SD-210 |  | Backfilling / Compaction, Bed Preparation, Polyethylene Sheet Vapor Barrier | 17.6d | 2017-01-05 | 2017-01-25 | CON-Z3-UTI-SD-200 SS+4d, CON-Z3-UTI-SD-200 | 156d | 0d | Common Labor / Helper [104 h]; Painter [52 h]; Water Proofing Crew [52 h]; Operator - Loader [26 h]; Driver - Dump Truck [26 h]; Operator - Bobcat [26 h]; Operator - Roller-Compactor (2~10 Ton) [26 h]; Driver - Water Tanker [26 h]; Loader [28 h]; Dump Truck [28 h]; Bobcat [28 h]; Roller-Compactor (2~10 Ton) [28 h]; Plate Compactor [28 h]; Vibrators [28 h]; Water Tanker [28 h]; JCB [28 h] | 78,328.34 | 0 | 0 | 0.0199222112 | 6 | RPI - CONS | Z1 | STORM | CIVIL | 1.3.3.60 | CONS | CONS | ZONE-3 | ROAD-3 | CIVIL | STORM |
| CON-Z3-UTI-SD-220 |  | Welded Wire Mesh and Concrete Works | 35d | 2017-01-26 | 2017-03-07 | CON-Z3-UTI-SD-210 | 156d | 60.8d | Shuttering Carpenter [78 h]; Concrete Mason [78 h]; Common Labor / Helper [104 h]; Finishing Work Crew [52 h]; Driver - Conc. Transit Mixers [26 h]; Operator - Concrete Pump [26 h]; Concrete Transit Mixers [28 h]; Concrete Pump [28 h] | 125,325.34 | 0 | 0 | 0.0597666337 | 6 | RPI - CONS | Z1 | STORM | CIVIL | 1.3.3.60 | CONS | CONS | ZONE-3 | ROAD-3 | CIVIL | STORM |
| CON-Z3-UTI-SD-230 |  | Bitumen Coating & Backfilling | 48d | 2017-05-17 | 2017-07-17 | CON-Z3-UTI-SD-0200 SS, CON-Z3-UTI-SD-220 | 95.2d | 0d | Common Labor / Helper [52 h]; Painter [52 h]; Operator - Bobcat [26 h]; Operator - Roller-Compactor (2~10 Ton) [26 h]; Driver - Water Tanker [26 h]; Operator - JCB [26 h]; Bobcat [28 h]; Plate Compactor [28 h]; Vibrators [28 h]; Water Tanker [28 h]; JCB [28 h] | 62,662.67 | 0 | 0 | 0.0099611056 | 6 | RPI - CONS | Z1 | STORM | CIVIL | 1.3.3.60 | CONS | CONS | ZONE-3 | ROAD-3 | CIVIL | STORM |
|  | 7 | **Storm Water Ditch D-12 at Road A and Road B (2m Width -Type - II)** |  | 2017-01-05 | 2017-07-17 |  |  |  |  |  |  |  |  |  |  |  |  |  |  |  |  |  |  |  |  |
| CON-Z3-UTI-SD-240 |  | Excavation | 12d | 2017-01-05 | 2017-01-19 | CON-Z3-UTI-SD-200 | 129d | 0d | Common Labor / Helper [26 h] | 31,331.33 | 0 | 0 | 0.0099611056 | 6 | RPI - CONS | Z1 | STORM | CIVIL | 1.3.3.60 | CONS | CONS | ZONE-3 | ROAD-A | CIVIL | STORM |
| CON-Z3-UTI-SD-250 |  | Backfilling / Compaction, Bed Preparation, Polyethylene Sheet Vapor Barrier | 17.6d | 2017-01-19 | 2017-02-08 | CON-Z3-UTI-SD-240 SS+4d, CON-Z3-UTI-SD-240 | 144d | 0d | Common Labor / Helper [104 h]; Painter [52 h]; Water Proofing Crew [52 h]; Operator - Loader [26 h]; Driver - Dump Truck [26 h]; Operator - Bobcat [26 h]; Operator - Roller-Compactor (2~10 Ton) [26 h]; Driver - Water Tanker [26 h]; Loader [28 h]; Dump Truck [28 h]; Bobcat [28 h]; Roller-Compactor (2~10 Ton) [28 h]; Plate Compactor [28 h]; Vibrators [28 h]; Water Tanker [28 h]; JCB [28 h] | 52,218.89 | 0 | 0 | 0.0199222112 | 6 | RPI - CONS | Z1 | STORM | CIVIL | 1.3.3.60 | CONS | CONS | ZONE-3 | ROAD-A | CIVIL | STORM |
| CON-Z3-UTI-SD-260 |  | Welded Wire Mesh and Concrete Works | 35d | 2017-02-09 | 2017-03-21 | CON-Z3-UTI-SD-250 | 144d | 48.8d | Shuttering Carpenter [78 h]; Concrete Mason [78 h]; Common Labor / Helper [104 h]; Finishing Work Crew [52 h]; Driver - Conc. Transit Mixers [26 h]; Operator - Concrete Pump [26 h]; Concrete Transit Mixers [28 h]; Concrete Pump [28 h] | 83,550.22 | 0 | 0 | 0.0597666337 | 6 | RPI - CONS | Z1 | STORM | CIVIL | 1.3.3.60 | CONS | CONS | ZONE-3 | ROAD-A | CIVIL | STORM |
| CON-Z3-UTI-SD-270 |  | Bitumen Coating & Backfilling | 48d | 2017-05-17 | 2017-07-17 | CON-Z3-UTI-SD-260, CON-Z3-UTI-SD-230 SS | 95.2d | 0d | Common Labor / Helper [52 h]; Painter [52 h]; Operator - Bobcat [26 h]; Operator - Roller-Compactor (2~10 Ton) [26 h]; Driver - Water Tanker [26 h]; Operator - JCB [26 h]; Bobcat [28 h]; Plate Compactor [28 h]; Vibrators [28 h]; Water Tanker [28 h]; JCB [28 h] | 41,775.11 | 0 | 0 | 0.0099611056 | 6 | RPI - CONS | Z1 | STORM | CIVIL | 1.3.3.60 | CONS | CONS | ZONE-3 | ROAD-A | CIVIL | STORM |

Notes:
- CON-Z3-UTI-SD-0090: Expenses: (New Expense Item) 15665.7
- CON-Z3-UTI-SD-0100: Expenses: (New Expense Item) 26109.4
- CON-Z3-UTI-SD-0110: Expenses: (New Expense Item) 41775.1
- CON-Z3-UTI-SD-0120: Expenses: (New Expense Item) 20887.6
- CON-Z3-UTI-SD-0130: Expenses: (New Expense Item) 46997
- CON-Z3-UTI-SD-0140: Expenses: (New Expense Item) 78328.3
- CON-Z3-UTI-SD-0150: Expenses: (New Expense Item) 125325
- CON-Z3-UTI-SD-0160: Expenses: (New Expense Item) 62662.7
- CON-Z3-UTI-SD-0170: Expenses: (New Expense Item) 46997
- CON-Z3-UTI-SD-0180: Expenses: (New Expense Item) 78328.3
- CON-Z3-UTI-SD-0190: Expenses: (New Expense Item) 125325
- CON-Z3-UTI-SD-0200: Expenses: (New Expense Item) 62662.7
- CON-Z3-UTI-SD-200: Expenses: (New Expense Item) 46997
- CON-Z3-UTI-SD-210: Expenses: (New Expense Item) 78328.3
- CON-Z3-UTI-SD-220: Expenses: (New Expense Item) 125325
- CON-Z3-UTI-SD-230: Expenses: (New Expense Item) 62662.7
- CON-Z3-UTI-SD-240: Expenses: (New Expense Item) 31331.3
- CON-Z3-UTI-SD-250: Expenses: (New Expense Item) 52218.9
- CON-Z3-UTI-SD-260: Expenses: (New Expense Item) 83550.2
- CON-Z3-UTI-SD-270: Expenses: (New Expense Item) 41775.1

| ID | WBS | Activity | Duration | Start | Finish | Predecessors | Total float | Free float | Resources | Cost | Activity Wt% | Weight % | Cost Wt | RPI - PHASE | RPI - CONSTRUCTION | RPI - ZONES | RPI - UTILITY NETWORKS | RPI - TYPE OF WORK | RPI_P2 - BOQ ITEMS | RPI_P2 - CONSTRUCTION | RPI_P2 - PHASE | RPI_P2 - ZONES | RPI_P2 - AREAS | RPI_P2 - DISCIPLINE / WORK TYPE | RPI_P2 - UTILITY NETWORK |
| --- | --- | --- | --- | --- | --- | --- | --- | --- | --- | --- | --- | --- | --- | --- | --- | --- | --- | --- | --- | --- | --- | --- | --- | --- | --- |
|  | 8 | **Storm Water Ditch D-13 at Road 2 and Road B (2.5m Width -Type - II)** |  | 2017-01-19 | 2017-07-17 |  |  |  |  |  |  |  |  |  |  |  |  |  |  |  |  |  |  |  |  |
| CON-Z3-UTI-SD-280 |  | Excavation | 12d | 2017-01-19 | 2017-02-02 | CON-Z3-UTI-SD-240 | 129d | 0d | Common Labor / Helper [26 h] | 31,331.33 | 0 | 0 | 0.0099611056 | 6 | RPI - CONS | Z1 | STORM | CIVIL | 1.3.3.60 | CONS | CONS | ZONE-3 | ROAD-2 | CIVIL | STORM |
| CON-Z3-UTI-SD-290 |  | Backfilling / Compaction, Bed Preparation, Polyethylene Sheet Vapor Barrier | 17.6d | 2017-02-02 | 2017-02-22 | CON-Z3-UTI-SD-280, CON-Z3-UTI-SD-280 SS+4d | 132d | 0d | Common Labor / Helper [104 h]; Painter [52 h]; Water Proofing Crew [52 h]; Operator - Loader [26 h]; Driver - Dump Truck [26 h]; Operator - Bobcat [26 h]; Operator - Roller-Compactor (2~10 Ton) [26 h]; Driver - Water Tanker [26 h]; Loader [28 h]; Dump Truck [28 h]; Bobcat [28 h]; Roller-Compactor (2~10 Ton) [28 h]; Plate Compactor [28 h]; Vibrators [28 h]; Water Tanker [28 h]; JCB [28 h] | 52,218.89 | 0 | 0 | 0.0199222112 | 6 | RPI - CONS | Z1 | STORM | CIVIL | 1.3.3.60 | CONS | CONS | ZONE-3 | ROAD-2 | CIVIL | STORM |
| CON-Z3-UTI-SD-300 |  | Welded Wire Mesh and Concrete Works | 35d | 2017-02-23 | 2017-04-04 | CON-Z3-UTI-SD-290 | 132d | 36.8d | Operator - Concrete Pump [26 h]; Concrete Transit Mixers [28 h]; Concrete Pump [28 h]; Shuttering Carpenter [78 h]; Concrete Mason [78 h]; Common Labor / Helper [104 h]; Finishing Work Crew [52 h]; Driver - Conc. Transit Mixers [26 h] | 83,550.22 | 0 | 0 | 0.0597666337 | 6 | RPI - CONS | Z1 | STORM | CIVIL | 1.3.3.60 | CONS | CONS | ZONE-3 | ROAD-2 | CIVIL | STORM |
| CON-Z3-UTI-SD-310 |  | Bitumen Coating & Backfilling | 48d | 2017-05-17 | 2017-07-17 | CON-Z3-UTI-SD-270 SS, CON-Z3-UTI-SD-300 | 95.2d | 0d | Common Labor / Helper [52 h]; Painter [52 h]; Operator - Bobcat [26 h]; Operator - Roller-Compactor (2~10 Ton) [26 h]; Driver - Water Tanker [26 h]; Operator - JCB [26 h]; Bobcat [28 h]; Plate Compactor [28 h]; Vibrators [28 h]; Water Tanker [28 h]; JCB [28 h] | 41,775.11 | 0 | 0 | 0.0099611056 | 6 | RPI - CONS | Z1 | STORM | CIVIL | 1.3.3.60 | CONS | CONS | ZONE-3 | ROAD-2 | CIVIL | STORM |
|  | 9 | **Storm Water Ditch D-14 at Road A (2m Width -Type - I)** |  | 2017-02-02 | 2017-07-19 |  |  |  |  |  |  |  |  |  |  |  |  |  |  |  |  |  |  |  |  |
| CON-Z3-UTI-SD-320 |  | Excavation | 9.6d | 2017-02-02 | 2017-02-13 | CON-Z3-UTI-SD-280 | 129d | 0d | Common Labor / Helper [26 h] | 15,665.67 | 0 | 0 | 0.0099611056 | 6 | RPI - CONS | Z1 | STORM | CIVIL | 1.3.3.60 | CONS | CONS | ZONE-3 | ROAD-A | CIVIL | STORM |
| CON-Z3-UTI-SD-330 |  | Backfilling / Compaction, Bed Preparation, Polyethylene Sheet Vapor Barrier | 16d | 2017-02-14 | 2017-03-04 | CON-Z3-UTI-SD-320 SS+4d, CON-Z3-UTI-SD-320 | 129d | 0d | Common Labor / Helper [104 h]; Painter [52 h]; Water Proofing Crew [52 h]; Operator - Loader [26 h]; Driver - Dump Truck [26 h]; Operator - Bobcat [26 h]; Operator - Roller-Compactor (2~10 Ton) [26 h]; Driver - Water Tanker [26 h]; Loader [28 h]; Roller-Compactor (2~10 Ton) [28 h]; Plate Compactor [28 h]; Vibrators [28 h]; Water Tanker [28 h]; JCB [28 h]; Dump Truck [28 h]; Bobcat [28 h] | 26,109.44 | 0 | 0 | 0.0199222112 | 6 | RPI - CONS | Z1 | STORM | CIVIL | 1.3.3.60 | CONS | CONS | ZONE-3 | ROAD-A | CIVIL | STORM |
| CON-Z3-UTI-SD-340 |  | Welded Wire Mesh and Concrete Works | 30d | 2017-03-05 | 2017-04-08 | CON-Z3-UTI-SD-330 | 129d | 33.8d | Shuttering Carpenter [78 h]; Concrete Mason [78 h]; Common Labor / Helper [104 h]; Finishing Work Crew [52 h]; Driver - Conc. Transit Mixers [26 h]; Operator - Concrete Pump [26 h]; Concrete Transit Mixers [28 h]; Concrete Pump [28 h] | 41,775.11 | 0 | 0 | 0.0597666337 | 6 | RPI - CONS | Z1 | STORM | CIVIL | 1.3.3.60 | CONS | CONS | ZONE-3 | ROAD-A | CIVIL | STORM |
| CON-Z3-UTI-SD-350 |  | Bitumen Coating & Backfilling | 50d | 2017-05-17 | 2017-07-19 | CON-Z3-UTI-SD-310 SS, CON-Z3-UTI-SD-340 | 95.2d | 0d | Water Tanker [28 h]; JCB [28 h]; Common Labor / Helper [52 h]; Painter [52 h]; Operator - Bobcat [26 h]; Operator - Roller-Compactor (2~10 Ton) [26 h]; Driver - Water Tanker [26 h]; Operator - JCB [26 h]; Bobcat [28 h]; Plate Compactor [28 h]; Vibrators [28 h] | 20,887.56 | 0 | 0 | 0.0099611056 | 6 | RPI - CONS | Z1 | STORM | CIVIL | 1.3.3.60 | CONS | CONS | ZONE-3 | ROAD-A | CIVIL | STORM |
|  | 10 | **Storm Water Ditch D-15 at Road A (2m Width -Type - I)** |  | 2017-02-14 | 2017-07-12 |  |  |  |  |  |  |  |  |  |  |  |  |  |  |  |  |  |  |  |  |
| CON-Z3-UTI-SD-360 |  | Excavation | 9.6d | 2017-02-14 | 2017-02-25 | CON-Z3-UTI-SD-320 | 135.8d | 0d | Common Labor / Helper [26 h] | 15,665.67 | 0 | 0 | 0.0099611056 | 6 | RPI - CONS | Z1 | STORM | CIVIL | 1.3.3.60 | CONS | CONS | ZONE-3 | ROAD-A | CIVIL | STORM |
| CON-Z3-UTI-SD-370 |  | Backfilling / Compaction, Bed Preparation, Polyethylene Sheet Vapor Barrier | 16d | 2017-02-25 | 2017-03-15 | CON-Z3-UTI-SD-360, CON-Z3-UTI-SD-360 SS+4d | 135.8d | 0d | Common Labor / Helper [104 h]; Painter [52 h]; Water Proofing Crew [52 h]; Operator - Loader [26 h]; Driver - Dump Truck [26 h]; Operator - Bobcat [26 h]; Operator - Roller-Compactor (2~10 Ton) [26 h]; Driver - Water Tanker [26 h]; Loader [28 h]; Dump Truck [28 h]; Bobcat [28 h]; Roller-Compactor (2~10 Ton) [28 h]; Plate Compactor [28 h]; JCB [28 h]; Vibrators [28 h]; Water Tanker [28 h] | 26,109.44 | 0 | 0 | 0.0199222112 | 6 | RPI - CONS | Z1 | STORM | CIVIL | 1.3.3.60 | CONS | CONS | ZONE-3 | ROAD-A | CIVIL | STORM |
| CON-Z3-UTI-SD-380 |  | Welded Wire Mesh and Concrete Works | 28d | 2017-02-27 | 2017-04-01 | CON-Z3-UTI-SD-370 SS+1.6d | 135.8d | 40.6d | Shuttering Carpenter [78 h]; Concrete Mason [78 h]; Common Labor / Helper [104 h]; Finishing Work Crew [52 h]; Driver - Conc. Transit Mixers [26 h]; Operator - Concrete Pump [26 h]; Concrete Transit Mixers [28 h]; Concrete Pump [28 h] | 41,775.11 | 0 | 0 | 0.0597666337 | 6 | RPI - CONS | Z1 | STORM | CIVIL | 1.3.3.60 | CONS | CONS | ZONE-3 | ROAD-A | CIVIL | STORM |
| CON-Z3-UTI-SD-390 |  | Bitumen Coating & Backfilling | 44d | 2017-05-17 | 2017-07-12 | CON-Z3-UTI-SD-350 SS, CON-Z3-UTI-SD-380 | 95.2d | 0d | Common Labor / Helper [52 h]; Painter [52 h]; Operator - Bobcat [26 h]; Operator - Roller-Compactor (2~10 Ton) [26 h]; Driver - Water Tanker [26 h]; Operator - JCB [26 h]; Bobcat [28 h]; Plate Compactor [28 h]; Vibrators [28 h]; Water Tanker [28 h]; JCB [28 h] | 20,887.56 | 0 | 0 | 0.0099611056 | 6 | RPI - CONS | Z1 | STORM | CIVIL | 1.3.3.60 | CONS | CONS | ZONE-3 | ROAD-A | CIVIL | STORM |
|  | 14 | **Box Culvert (Road A)** |  | 2017-02-25 | 2017-07-17 |  |  |  |  |  |  |  |  |  |  |  |  |  |  |  |  |  |  |  |  |
| CON-Z3-UTI-CUL-010 |  | Excavation | 2.4d | 2017-02-25 | 2017-02-27 | CON-Z3-UTI-SD-360 | 189.4d | 0d | Common Labor / Helper [26 h] | 10,443.78 | 0 | 0 | 0.0145580522 | 6 | RPI - CONS | Z2 | STORM | CIVIL | 1.3.3.60 | CONS | CONS | ZONE-3 | ROAD-A | CIVIL | STORM |
| CON-Z3-UTI-CUL-020 |  | Bed Preparation, Polyethylene Sheet Vapor Barrier | 1.6d | 2017-02-28 | 2017-03-01 | CON-Z3-UTI-CUL-010 | 189.4d | 0d | Common Labor / Helper [104 h] | 10,443.78 | 0 | 0 | 0.002448155 | 6 | RPI - CONS | Z2 | STORM | CIVIL | 1.3.3.60 | CONS | CONS | ZONE-3 | ROAD-A | CIVIL | STORM |
| CON-Z3-UTI-CUL-030 |  | Lean Concrete 200mm thk | 0.8d | 2017-03-01 | 2017-03-02 | CON-Z3-UTI-CUL-020 | 189.4d | 0d | Concrete Mason [10.4 h]; Driver - Conc. Transit Mixers [10.4 h]; Operator - Concrete Pump [10.4 h] | 5,221.89 | 0 | 0 | 0.0009188518 | 6 | RPI - CONS | Z2 | STORM | CIVIL | 1.3.3.60 | CONS | CONS | ZONE-3 | ROAD-A | CIVIL | STORM |
| CON-Z3-UTI-CUL-040 |  | Concrete Base Slab 300mm thk | 4.8d | 2017-03-02 | 2017-03-08 | CON-Z3-UTI-CUL-030 | 189.4d | 0d | Steel Fixer [78 h]; Shuttering Carpenter [78 h]; Concrete Mason [52 h]; Common Labor / Helper [52 h]; Finishing Work Crew [52 h]; Driver - Conc. Transit Mixers [26 h]; Operator - Concrete Pump [26 h]; Concrete Transit Mixers [28 h]; Concrete Pump [28 h] | 15,665.67 | 0 | 0 | 0.0160012184 | 6 | RPI - CONS | Z2 | STORM | CIVIL | 1.3.3.60 | CONS | CONS | ZONE-3 | ROAD-A | CIVIL | STORM |
| CON-Z3-UTI-CUL-050 |  | Concrete Wall 300mm thk | 5.6d | 2017-03-08 | 2017-03-14 | CON-Z3-UTI-CUL-040 | 189.4d | 0d | Steel Fixer [78 h]; Shuttering Carpenter [78 h]; Concrete Mason [52 h]; Common Labor / Helper [52 h]; Driver - Conc. Transit Mixers [26 h]; Scaffolder [26 h]; Finishing Work Crew [52 h]; Operator - Concrete Pump [26 h]; Concrete Transit Mixers [28 h]; Concrete Pump [28 h] | 26,109.44 | 0 | 0 | 0.0278544187 | 6 | RPI - CONS | Z2 | STORM | CIVIL | 1.3.3.60 | CONS | CONS | ZONE-3 | ROAD-A | CIVIL | STORM |
| CON-Z3-UTI-CUL-060 |  | Precast Cover 300mm thk | 2.4d | 2017-03-14 | 2017-03-18 | CON-Z3-UTI-CUL-050 | 189.4d | 0d | Steel Fixer [78 h]; Shuttering Carpenter [78 h]; Concrete Mason [52 h]; Common Labor / Helper [52 h]; Operator - Mobile Crane [26 h]; Mobile Crane ( 25-60 Ton) [28 h] | 15,665.67 | 0 | 0 | 0.0103233046 | 6 | RPI - CONS | Z2 | STORM | CIVIL | 1.3.3.60 | CONS | CONS | ZONE-3 | ROAD-A | CIVIL | STORM |
| CON-Z3-UTI-CUL-070 |  | External Water Proofing | 2.4d | 2017-03-18 | 2017-03-20 | CON-Z3-UTI-CUL-060 | 189.4d | 94.2d | Water Proofing Crew [52 h] | 5,221.89 | 0 | 0 | 0.0078676576 | 6 | RPI - CONS | Z2 | STORM | CIVIL | 1.3.3.60 | CONS | CONS | ZONE-3 | ROAD-A | CIVIL | STORM |
| CON-Z3-UTI-CUL-080 |  | Backfilling | 4d | 2017-07-12 | 2017-07-17 | CON-Z3-UTI-SD-390, CON-Z3-UTI-CUL-070 | 95.2d | 60.4d | Common Labor / Helper [104 h]; Road Works Crew [78 h]; Operator - Loader [26 h]; Driver - Dump Truck [26 h]; Operator - Roller (25 Ton) [26 h]; Driver - Fuel Tanker [26 h]; Bobcat [28 h]; Plate Compactor [168 h]; Vibrators [168 h]; Water Tanker [28 h]; JCB [28 h] | 15,665.67 | 0 | 0 | 0.0022396906 | 6 | RPI - CONS | Z2 | STORM | CIVIL | 1.3.3.60 | CONS | CONS | ZONE-3 | ROAD-A | CIVIL | STORM |

Notes:
- CON-Z3-UTI-SD-280: Expenses: (New Expense Item) 31331.3
- CON-Z3-UTI-SD-290: Expenses: (New Expense Item) 52218.9
- CON-Z3-UTI-SD-300: Expenses: (New Expense Item) 83550.2
- CON-Z3-UTI-SD-310: Expenses: (New Expense Item) 41775.1
- CON-Z3-UTI-SD-320: Expenses: (New Expense Item) 15665.7
- CON-Z3-UTI-SD-330: Expenses: (New Expense Item) 26109.4
- CON-Z3-UTI-SD-340: Expenses: (New Expense Item) 41775.1
- CON-Z3-UTI-SD-350: Expenses: (New Expense Item) 20887.6
- CON-Z3-UTI-SD-360: Expenses: (New Expense Item) 15665.7
- CON-Z3-UTI-SD-370: Expenses: (New Expense Item) 26109.4
- CON-Z3-UTI-SD-380: Expenses: (New Expense Item) 41775.1
- CON-Z3-UTI-SD-390: Expenses: (New Expense Item) 20887.6
- CON-Z3-UTI-CUL-010: Expenses: (New Expense Item) 10443.8
- CON-Z3-UTI-CUL-020: Expenses: (New Expense Item) 10443.8
- CON-Z3-UTI-CUL-030: Expenses: (New Expense Item) 5221.89
- CON-Z3-UTI-CUL-040: Expenses: (New Expense Item) 15665.7
- CON-Z3-UTI-CUL-050: Expenses: (New Expense Item) 26109.4
- CON-Z3-UTI-CUL-060: Expenses: (New Expense Item) 15665.7
- CON-Z3-UTI-CUL-070: Expenses: (New Expense Item) 5221.89
- CON-Z3-UTI-CUL-080: Expenses: (New Expense Item) 15665.7

| ID | WBS | Activity | Duration | Start | Finish | Predecessors | Total float | Free float | Resources | Cost | RPI_P2 - BOQ ITEMS | RPI_P2 - CONSTRUCTION | RPI_P2 - PHASE | RPI_P2 - ZONES | RPI_P2 - DISCIPLINE / WORK TYPE | RPI_P2 - BUILDINGS | RPI_P2 - UTILITY NETWORK |
| --- | --- | --- | --- | --- | --- | --- | --- | --- | --- | --- | --- | --- | --- | --- | --- | --- | --- |
|  | 1 | **Drainage Ponds** |  | 2016-12-03 | 2017-10-02 |  |  |  |  |  |  |  |  |  |  |  |  |
|  | 3 | **Drainage Pond - 4** |  | 2016-12-03 | 2017-02-14 |  |  |  |  |  |  |  |  |  |  |  |  |
| CON-Z3-POND-04-0010 |  | Excavation | 12d | 2016-12-03 | 2016-12-17 | CON-Z3-UTI-SD-0010 SS+30d | 34.8d | 0d | Operator - Excavator [78 h]; Excavator [84 h] | 27,850.07 | 1.3.3.60 | CONS | CONS | ZONE-3 | CIVIL | Drainage P-4 | STORM |
| CON-Z3-POND-04-0020 |  | Compacted Marl Fill 500mm thk for Pond | 32d | 2016-12-08 | 2017-01-15 | CON-Z3-POND-04-0010 SS+5d | 240.8d | 0d | Common Labor / Helper [130 h]; Operator - Loader [52 h]; Driver - Dump Truck [104 h]; Operator - Bobcat [26 h]; Operator - Roller (25 Ton) [26 h]; Driver - Water Tanker [26 h]; Driver - Fuel Tanker [26 h]; Loader [56 h]; Dump Truck [112 h]; Bobcat [28 h]; Roller-Compactor (25 Ton) [56 h]; Water Tanker [28 h]; Dewatering Pumps [28 h] | 97,475.26 | 1.3.3.60 | CONS | CONS | ZONE-3 | CIVIL | Drainage P-4 | STORM |
| CON-Z3-POND-04-0030 |  | Marl Caping 200mm thk | 16d | 2016-12-13 | 2017-01-01 | CON-Z3-POND-04-0020 SS+4d | 240.8d | 0d | Common Labor / Helper [130 h] | 55,700.15 | 1.3.3.60 | CONS | CONS | ZONE-3 | CIVIL | Drainage P-4 | STORM |
| CON-Z3-POND-04-0040 |  | Compacted Marl Fill 500mm thk for Walkway | 12d | 2016-12-19 | 2017-01-02 | CON-Z3-POND-04-0030 SS+5d | 240.8d | 36d | Driver - Water Tanker [26 h]; Roller-Compactor (25 Ton) [28 h]; Water Tanker [28 h]; Common Labor / Helper [130 h]; Operator - Roller (25 Ton) [26 h] | 27,850.07 | 1.3.3.60 | CONS | CONS | ZONE-3 | CIVIL | Drainage P-4 | STORM |
| CON-Z3-POND-04-0050 |  | Instalaltion of Chain Link Fence and Gates | 8d | 2017-02-05 | 2017-02-14 | PR-Z3-GE-GE-221-0080, CON-Z3-POND-04-0040 SS+5d | 204.8d | 0d | Shuttering Carpenter [52 h]; Concrete Mason [52 h]; Welder [26 h]; Common Labor / Helper [104 h]; Operator - Forklift [26 h] | 69,625.19 | 1.3.3.60 | CONS | CONS | ZONE-3 | CIVIL | Drainage P-4 | STORM |
|  | 4 | **Drainage Pond - 7** |  | 2016-12-17 | 2017-02-23 |  |  |  |  |  |  |  |  |  |  |  |  |
| CON-Z3-POND-07-0010 |  | Excavation | 12d | 2016-12-17 | 2016-12-31 | CON-Z3-POND-04-0010 | 34.8d | 0d | Operator - Excavator [78 h]; Excavator [84 h] | 27,850.07 | 1.3.3.60 | CONS | CONS | ZONE-3 | CIVIL | Drainage P-7 | STORM |
| CON-Z3-POND-07-0020 |  | Compacted Marl Fill 500mm thk for Pond | 32d | 2016-12-22 | 2017-01-29 | CON-Z3-POND-07-0010 SS+5d | 225.8d | 0d | Common Labor / Helper [130 h]; Operator - Loader [52 h]; Driver - Dump Truck [104 h]; Operator - Bobcat [26 h]; Operator - Roller (25 Ton) [26 h]; Driver - Water Tanker [26 h]; Driver - Fuel Tanker [26 h]; Loader [56 h]; Dump Truck [112 h]; Bobcat [28 h]; Roller-Compactor (25 Ton) [56 h]; Water Tanker [28 h]; Dewatering Pumps [28 h] | 97,475.26 | 1.3.3.60 | CONS | CONS | ZONE-3 | CIVIL | Drainage P-7 | STORM |
| CON-Z3-POND-07-0030 |  | Marl Caping 200mm thk | 16d | 2016-12-27 | 2017-01-15 | CON-Z3-POND-07-0020 SS+4d | 225.8d | 0d | Common Labor / Helper [130 h] | 55,700.15 | 1.3.3.60 | CONS | CONS | ZONE-3 | CIVIL | Drainage P-7 | STORM |
| CON-Z3-POND-07-0040 |  | Compacted Marl Fill 500mm thk for Walkway | 12d | 2017-01-15 | 2017-01-29 | CON-Z3-POND-07-0030 | 225.8d | 21d | Common Labor / Helper [130 h]; Operator - Roller (25 Ton) [26 h]; Driver - Water Tanker [26 h]; Roller-Compactor (25 Ton) [28 h]; Water Tanker [28 h] | 27,850.07 | 1.3.3.60 | CONS | CONS | ZONE-3 | CIVIL | Drainage P-7 | STORM |
| CON-Z3-POND-07-0050 |  | Instalaltion of Chain Link Fence and Gates | 8d | 2017-02-14 | 2017-02-23 | CON-Z3-POND-04-0050, CON-Z3-POND-07-0040 SS+5d | 204.8d | 149d | Shuttering Carpenter [52 h]; Concrete Mason [52 h]; Welder [26 h]; Common Labor / Helper [104 h]; Operator - Forklift [26 h] | 69,625.19 | 1.3.3.60 | CONS | CONS | ZONE-3 | CIVIL | Drainage P-7 | STORM |
|  | 5 | **Drainage Pond - 8** |  | 2017-07-30 | 2017-09-16 |  |  |  |  |  |  |  |  |  |  |  |  |
| CON-Z3-POND-08-0010 |  | Excavation | 12d | 2017-07-30 | 2017-08-13 | CON-Z3-POND-07-0010 FS+177d | 34.8d | 0d | Operator - Excavator [78 h]; Excavator [84 h] | 27,850.07 | 1.3.3.60 | CONS | CONS | ZONE-3 | CIVIL | Drainage P-8 | STORM |
| CON-Z3-POND-08-0020 |  | Compacted Marl Fill 500mm thk for Pond | 32d | 2017-08-05 | 2017-09-16 | CON-Z3-POND-08-0010 SS+5d | 55.8d | 0d | Common Labor / Helper [130 h]; Operator - Loader [52 h]; Operator - Roller (25 Ton) [26 h]; Driver - Water Tanker [26 h]; Driver - Fuel Tanker [26 h]; Loader [56 h]; Dump Truck [112 h]; Bobcat [28 h]; Roller-Compactor (25 Ton) [56 h]; Water Tanker [28 h]; Dewatering Pumps [28 h]; Driver - Dump Truck [104 h]; Operator - Bobcat [26 h] | 97,475.26 | 1.3.3.60 | CONS | CONS | ZONE-3 | CIVIL | Drainage P-8 | STORM |
| CON-Z3-POND-08-0030 |  | Marl Caping 200mm thk | 16d | 2017-08-09 | 2017-08-28 | CON-Z3-POND-08-0020 SS+4d | 55.8d | 0d | Common Labor / Helper [1248 h]; Roller-Compactor (25 Ton) [448 h]; Operator - Roller (25 Ton) [416 h]; Loader [448 h]; Operator - Loader [416 h]; Water Tanker [224 h]; Driver - Water Tanker [208 h] | 55,700.15 | 1.3.3.60 | CONS | CONS | ZONE-3 | CIVIL | Drainage P-8 | STORM |
| CON-Z3-POND-08-0040 |  | Compacted Marl Fill 500mm thk for Walkway | 12d | 2017-08-15 | 2017-08-29 | CON-Z3-POND-08-0030 SS+5d | 55.8d | 0d | Common Labor / Helper [780 h]; Operator - Roller (25 Ton) [156 h]; Driver - Water Tanker [156 h]; Roller-Compactor (25 Ton) [168 h]; Water Tanker [168 h] | 27,850.07 | 1.3.3.60 | CONS | CONS | ZONE-3 | CIVIL | Drainage P-8 | STORM |
| CON-Z3-POND-08-0050 |  | Instalaltion of Chain Link Fence and Gates | 8d | 2017-08-21 | 2017-08-30 | CON-Z3-POND-07-0050, CON-Z3-POND-08-0040 SS+5d | 55.8d | 12d | Shuttering Carpenter [416 h]; Concrete Mason [416 h]; Welder [104 h]; Common Labor / Helper [624 h]; Operator - Forklift [104 h] | 69,625.19 | 1.3.3.60 | CONS | CONS | ZONE-3 | CIVIL | Drainage P-8 | STORM |
|  | 6 | **Drainage Pond - 9** |  | 2017-08-13 | 2017-10-01 |  |  |  |  |  |  |  |  |  |  |  |  |
| CON-Z3-POND-09-0010 |  | Excavation | 12d | 2017-08-13 | 2017-08-27 | CON-Z3-POND-08-0010 | 34.8d | 0d | Operator - Excavator [468 h]; Excavator [504 h] | 27,850.07 | 1.3.3.60 | CONS | CONS | ZONE-3 | CIVIL | Drainage P-9 | STORM |
| CON-Z3-POND-09-0020 |  | Compacted Marl Fill 500mm thk for Pond | 32d | 2017-08-19 | 2017-10-01 | CON-Z3-POND-09-0010 SS+5d | 43.8d | 0d | Common Labor / Helper [2496 h]; Operator - Loader [416 h]; Driver - Dump Truck [416 h]; Operator - Bobcat [416 h]; Operator - Roller (25 Ton) [416 h]; Driver - Water Tanker [416 h]; Driver - Fuel Tanker [416 h]; Loader [448 h]; Dump Truck [448 h]; Bobcat [448 h]; Roller-Compactor (25 Ton) [448 h]; Water Tanker [448 h]; Dewatering Pumps [448 h] | 97,475.26 | 1.3.3.60 | CONS | CONS | ZONE-3 | CIVIL | Drainage P-9 | STORM |
| CON-Z3-POND-09-0030 |  | Marl Caping 200mm thk | 16d | 2017-08-23 | 2017-09-16 | CON-Z3-POND-09-0020 SS+4d | 43.8d | 0d | Common Labor / Helper [1248 h] | 55,700.15 | 1.3.3.60 | CONS | CONS | ZONE-3 | CIVIL | Drainage P-9 | STORM |
| CON-Z3-POND-09-0040 |  | Compacted Marl Fill 500mm thk for Walkway | 12d | 2017-08-29 | 2017-09-17 | CON-Z3-POND-09-0030 SS+5d | 43.8d | 0d | Common Labor / Helper [1248 h]; Operator - Roller (25 Ton) [312 h]; Driver - Water Tanker [156 h]; Roller-Compactor (25 Ton) [336 h]; Water Tanker [168 h] | 27,850.07 | 1.3.3.60 | CONS | CONS | ZONE-3 | CIVIL | Drainage P-9 | STORM |
| CON-Z3-POND-09-0050 |  | Instalaltion of Chain Link Fence and Gates | 8d | 2017-09-09 | 2017-09-18 | CON-Z3-POND-09-0040 SS+5d, CON-Z3-POND-08-0050 SS | 43.8d | 9d | Shuttering Carpenter [52 h]; Concrete Mason [52 h]; Welder [26 h]; Common Labor / Helper [104 h]; Operator - Forklift [26 h] | 69,625.19 | 1.3.3.60 | CONS | CONS | ZONE-3 | CIVIL | Drainage P-9 | STORM |

Notes:
- CON-Z3-POND-04-0010: Expenses: (New Expense Item) 27850.1
- CON-Z3-POND-04-0020: Expenses: (New Expense Item) 97475.3
- CON-Z3-POND-04-0030: Expenses: (New Expense Item) 55700.2
- CON-Z3-POND-04-0040: Expenses: (New Expense Item) 27850.1
- CON-Z3-POND-04-0050: Expenses: (New Expense Item) 69625.2
- CON-Z3-POND-07-0010: Expenses: (New Expense Item) 27850.1
- CON-Z3-POND-07-0020: Expenses: (New Expense Item) 97475.3
- CON-Z3-POND-07-0030: Expenses: (New Expense Item) 55700.2
- CON-Z3-POND-07-0040: Expenses: (New Expense Item) 27850.1
- CON-Z3-POND-07-0050: Expenses: (New Expense Item) 69625.2
- CON-Z3-POND-08-0010: Expenses: (New Expense Item) 27850.1
- CON-Z3-POND-08-0020: Expenses: (New Expense Item) 97475.3
- CON-Z3-POND-08-0030: Expenses: (New Expense Item) 55700.2
- CON-Z3-POND-08-0040: Expenses: (New Expense Item) 27850.1
- CON-Z3-POND-08-0050: Expenses: (New Expense Item) 69625.2
- CON-Z3-POND-09-0010: Expenses: (New Expense Item) 27850.1
- CON-Z3-POND-09-0020: Expenses: (New Expense Item) 97475.3
- CON-Z3-POND-09-0030: Expenses: (New Expense Item) 55700.2
- CON-Z3-POND-09-0040: Expenses: (New Expense Item) 27850.1
- CON-Z3-POND-09-0050: Expenses: (New Expense Item) 69625.2

| ID | WBS | Activity | Duration | Start | Finish | Predecessors | Total float | Free float | Resources | Cost | RPI_P2 - BOQ ITEMS | RPI_P2 - CONSTRUCTION | RPI_P2 - PHASE | RPI_P2 - ZONES | RPI_P2 - DISCIPLINE / WORK TYPE | RPI_P2 - BUILDINGS | RPI_P2 - UTILITY NETWORK | RPI_P2 - AREAS |
| --- | --- | --- | --- | --- | --- | --- | --- | --- | --- | --- | --- | --- | --- | --- | --- | --- | --- | --- |
|  | 7 | **Drainage Pond - 6** |  | 2017-08-27 | 2017-10-02 |  |  |  |  |  |  |  |  |  |  |  |  |  |
| CON-Z3-POND-06-0010 |  | Excavation | 12d | 2017-08-27 | 2017-09-14 | CON-Z3-POND-09-0010 | 34.8d | 0d | Operator - Excavator [312 h]; Excavator [336 h] | 27,850.07 | 1.3.3.60 | CONS | CONS | ZONE-3 | CIVIL | Drainage P-6 | STORM |  |
| CON-Z3-POND-06-0020 |  | Compacted Marl Fill 500mm thk for Pond | 20d | 2017-09-06 | 2017-10-01 | CON-Z3-POND-06-0010 SS+5d | 34.8d | 0d | Common Labor / Helper [130 h]; Operator - Loader [52 h]; Driver - Dump Truck [104 h]; Operator - Bobcat [26 h]; Operator - Roller (25 Ton) [26 h]; Driver - Water Tanker [26 h]; Driver - Fuel Tanker [26 h]; Loader [56 h]; Dump Truck [112 h]; Bobcat [28 h]; Roller-Compactor (25 Ton) [56 h]; Water Tanker [28 h]; Dewatering Pumps [28 h] | 97,475.26 | 1.3.3.60 | CONS | CONS | ZONE-3 | CIVIL | Drainage P-6 | STORM |  |
| CON-Z3-POND-06-0030 |  | Marl Caping 200mm thk | 16d | 2017-09-11 | 2017-10-01 | CON-Z3-POND-06-0020 SS+4d | 34.8d | 0d | Common Labor / Helper [130 h] | 55,700.15 | 1.3.3.60 | CONS | CONS | ZONE-3 | CIVIL | Drainage P-6 | STORM |  |
| CON-Z3-POND-06-0040 |  | Compacted Marl Fill 500mm thk for Walkway | 12d | 2017-09-17 | 2017-10-02 | CON-Z3-POND-06-0030 SS+5d | 34.8d | 0d | Water Tanker [28 h]; Common Labor / Helper [130 h]; Operator - Roller (25 Ton) [26 h]; Driver - Water Tanker [26 h]; Roller-Compactor (25 Ton) [28 h] | 27,850.07 | 1.3.3.60 | CONS | CONS | ZONE-3 | CIVIL | Drainage P-6 | STORM |  |
| CON-Z3-POND-06-0050 |  | Instalaltion of Chain Link Fence and Gates | 10d | 2017-09-19 | 2017-10-02 | CON-Z3-POND-06-0040 SS+2d, CON-Z3-POND-09-0050 SS | 34.8d | 0d | Shuttering Carpenter [52 h]; Concrete Mason [52 h]; Welder [26 h]; Common Labor / Helper [104 h]; Operator - Forklift [26 h] | 69,625.19 | 1.3.3.60 | CONS | CONS | ZONE-3 | CIVIL | Drainage P-6 | STORM |  |
|  | 7 | **Road Networks** |  | 2016-10-23 | 2017-08-03 |  |  |  |  |  |  |  |  |  |  |  |  |  |
|  | 3 | **New Roads** |  | 2017-02-14 | 2017-07-17 |  |  |  |  |  |  |  |  |  |  |  |  |  |
|  | 1 | **Road A** |  | 2017-02-14 | 2017-07-12 |  |  |  |  |  |  |  |  |  |  |  |  |  |
| CON-Z3-UTI-RD-RA-010 |  | Clearing & Grubbing | 10d | 2017-02-14 | 2017-02-26 | CON-CON-CON-CON-0010 FS+158d | 50.8d | 0d | Common Labor / Helper [78 h]; Operator - Loader [26 h]; Operator - Grader [26 h]; Loader [28 h]; Grader [28 h] | 43,364.73 | 1.3.3.70 | CONS | CONS | ZONE-3 | ROAD |  | ROAD | ROAD-A |
| CON-Z3-UTI-RD-RA-020 |  | Backfilling Works | 20d | 2017-02-18 | 2017-03-13 | CON-Z3-UTI-RD-RA-010 SS+3d | 86.8d | 0d | Common Labor / Helper [104 h]; Road Works Crew [78 h]; Operator - Loader [26 h]; Driver - Dump Truck [26 h]; Operator - Roller (25 Ton) [26 h]; Driver - Fuel Tanker [26 h]; Loader [28 h]; Dump Truck [28 h]; Bobcat [28 h]; Roller-Compactor (2~10 Ton) [28 h]; Roller-Compactor (25 Ton) [28 h]; Water Tanker [28 h] | 86,729.46 | 1.3.3.70 | CONS | CONS | ZONE-3 | ROAD |  | ROAD | ROAD-A |
| CON-Z3-UTI-RD-RA-030 |  | Road Curbs & Gutter | 50d | 2017-05-01 | 2017-07-03 | PR-Z3-CW-CW-21-0080, CON-Z3-UTI-RD-RA-020 SS+62d | 86.8d | 0d | Steel Fixer [52 h]; Shuttering Carpenter [104 h]; Concrete Mason [78 h]; Common Labor / Helper [78 h]; Driver - Conc. Transit Mixers [26 h]; Operator - Concrete Pump [26 h]; Concrete Transit Mixers [28 h]; Concrete Pump [28 h] | 130,094.19 | 1.3.3.70 | CONS | CONS | ZONE-3 | ROAD |  | ROAD | ROAD-A |
| CON-Z3-UTI-RD-RA-040 |  | Laying of Geo Grid and Geotextile | 20d | 2017-05-07 | 2017-05-30 | PR-Z3-CW-RW-17-0080, CON-Z3-UTI-RD-RA-030 SS+5d, PR-Z3-CW-RW-16-0080 | 86.8d | 0d | Common Labor / Helper [78 h]; Road Works Crew [52 h] | 43,364.73 | 1.3.3.70 | CONS | CONS | ZONE-3 | ROAD |  | ROAD | ROAD-A |
| CON-Z3-UTI-RD-RA-050 |  | Laying & Compaction of Sub-Base | 40d | 2017-05-10 | 2017-07-01 | CON-Z3-UTI-RD-RA-040 SS+3d, PR-Z3-CW-RW-18-0080 | 86.8d | 0d | Common Labor / Helper [104 h]; Road Works Crew [52 h]; Operator - Loader [26 h]; Driver - Dump Truck [78 h]; Operator - Grader [26 h]; Operator - Roller (25 Ton) [26 h]; Driver - Water Tanker [52 h]; Driver - Fuel Tanker [26 h]; Drivers Light Duty [26 h]; Loader [28 h]; Dump Truck [84 h]; Grader [28 h]; Bobcat [28 h]; Roller-Compactor (25 Ton) [56 h]; Water Tanker [56 h]; Fuel Tanker [28 h] | 130,094.19 | 1.3.3.70 | CONS | CONS | ZONE-3 | ROAD |  | ROAD | ROAD-A |
| CON-Z3-UTI-RD-RA-060 |  | Laying & Compaction of Base Course | 30d | 2017-05-22 | 2017-07-01 | CON-Z3-UTI-RD-RA-050 SS+10d, PR-Z3-CW-RW-18-0080 | 86.8d | 0d | Common Labor / Helper [52 h]; Road Works Crew [52 h]; Operator - Loader [26 h]; Driver - Dump Truck [26 h]; Operator - Grader [26 h]; Driver - Water Tanker [26 h]; Loader [28 h]; Dump Truck [28 h]; Grader [28 h]; Roller-Compactor (25 Ton) [28 h]; Water Tanker [28 h] | 86,729.46 | 1.3.3.70 | CONS | CONS | ZONE-3 | ROAD |  | ROAD | ROAD-A |
| CON-Z3-UTI-RD-RA-070 |  | Laying & Compaction of Prime Coat and Asphalt Binder Course | 25d | 2017-05-28 | 2017-07-01 | PR-Z3-CW-RW-19-0080, CON-Z3-UTI-RD-RA-060 SS+5d | 86.8d | 0d | Common Labor / Helper [52 h]; Road Works Crew [52 h]; Operator - Asphalt Paver [26 h]; Operator - Asphalt Compactor / Roller [26 h]; Operator - Roller (25 Ton) [26 h]; Asphalt Paver [28 h]; Asphalt Compactor / Roller [28 h]; Roller-Compactor (25 Ton) [28 h]; Fuel Tanker [28 h] | 130,094.19 | 1.3.3.70 | CONS | CONS | ZONE-3 | ROAD |  | ROAD | ROAD-A |
| CON-Z3-UTI-RD-RA-080 |  | Waering Course | 10d | 2017-06-03 | 2017-06-14 | CON-Z3-UTI-RD-RA-070 SS+5d | 86.8d | 0d | Common Labor / Helper [78 h]; Road Works Crew [52 h]; Driver - Dump Truck [26 h]; Operator - Asphalt Paver [26 h]; Operator - Roller (25 Ton) [26 h]; Dump Truck [28 h]; Asphalt Paver [28 h]; Asphalt Compactor / Roller [28 h] | 86,729.46 | 1.3.3.70 | CONS | CONS | ZONE-3 | ROAD |  | ROAD | ROAD-A |
| CON-Z3-UTI-RD-RA-090 |  | Pavement Marking | 15d | 2017-06-14 | 2017-07-06 | CON-Z3-UTI-RD-RA-080, PR-Z3-CW-MS-29-0080 | 86.8d | 0d | Common Labor / Helper [104 h]; Specialist Works Crew [26 h] | 43,364.73 | 1.3.3.70 | CONS | CONS | ZONE-3 | ROAD |  | ROAD | ROAD-A |
| CON-Z3-UTI-RD-RA-100 |  | Installation of Road Sings | 20d | 2017-06-14 | 2017-07-12 | CON-Z3-UTI-RD-RA-090 SS | 86.8d | 0d | Common Labor / Helper [78 h] | 43,364.73 | 1.3.3.70 | CONS | CONS | ZONE-3 | ROAD |  | ROAD | ROAD-A |
| CON-Z3-UTI-RD-RA-110 |  | Gravel Mulch for Buffer | 15d | 2017-06-14 | 2017-07-06 | CON-Z3-UTI-RD-RA-100 SS, PR-Z3-CW-CW-20-0080 | 86.8d | 14d | Common Labor / Helper [104 h]; Road Works Crew [52 h]; Operator - Loader [26 h]; Driver - Dump Truck [52 h]; Operator - Bobcat [26 h]; Loader [28 h]; Dump Truck [56 h]; Bobcat [28 h] | 43,364.73 | 1.3.3.70 | CONS | CONS | ZONE-3 | ROAD |  | ROAD | ROAD-A |
|  | 2 | **Road B** |  | 2017-02-26 | 2017-07-17 |  |  |  |  |  |  |  |  |  |  |  |  |  |
| CON-Z3-UTI-RD-RB-010 |  | Clearing & Grubbing | 5d | 2017-02-26 | 2017-03-04 | CON-Z3-UTI-RD-RA-010 SS+10d | 72.8d | 0d | Common Labor / Helper [78 h]; Operator - Loader [26 h]; Operator - Grader [26 h]; Loader [28 h]; Grader [28 h] | 18,584.88 | 1.3.3.70 | CONS | CONS | ZONE-3 | ROAD |  | ROAD | ROAD-B |
| CON-Z3-UTI-RD-RB-020 |  | Backfilling Works including 3 m buffer | 10d | 2017-03-01 | 2017-03-13 | CON-Z3-UTI-RD-RB-010 SS+3d | 72.8d | 0d | Common Labor / Helper [104 h]; Road Works Crew [78 h]; Operator - Loader [26 h]; Driver - Dump Truck [26 h]; Operator - Roller (25 Ton) [26 h]; Driver - Fuel Tanker [26 h]; Loader [28 h]; Dump Truck [28 h]; Bobcat [28 h]; Roller-Compactor (2~10 Ton) [28 h]; Roller-Compactor (25 Ton) [28 h]; Water Tanker [28 h] | 37,169.77 | 1.3.3.70 | CONS | CONS | ZONE-3 | ROAD |  | ROAD | ROAD-B |
| CON-Z3-UTI-RD-RB-030 |  | Road Curbs & Gutter | 25d | 2017-04-30 | 2017-05-29 | CON-Z3-UTI-RD-RB-020 SS+51d, PR-Z3-CW-CW-21-0080 | 72.8d | 0d | Steel Fixer [52 h]; Shuttering Carpenter [104 h]; Concrete Mason [78 h]; Common Labor / Helper [78 h]; Driver - Conc. Transit Mixers [26 h]; Operator - Concrete Pump [26 h]; Concrete Transit Mixers [28 h]; Concrete Pump [28 h] | 55,754.65 | 1.3.3.70 | CONS | CONS | ZONE-3 | ROAD |  | ROAD | ROAD-B |
| CON-Z3-UTI-RD-RB-040 |  | Laying of Geo Grid and Geotextile | 10d | 2017-05-06 | 2017-05-17 | CON-Z3-UTI-RD-RB-030 SS+5d | 72.8d | 0d | Common Labor / Helper [78 h]; Road Works Crew [52 h] | 18,584.88 | 1.3.3.70 | CONS | CONS | ZONE-3 | ROAD |  | ROAD | ROAD-B |
| CON-Z3-UTI-RD-RB-050 |  | Laying & Compaction of Sub-Base | 20d | 2017-05-09 | 2017-06-01 | PR-Z3-CW-RW-18-0080, CON-Z3-UTI-RD-RB-040 SS+3d | 72.8d | 0d | Common Labor / Helper [104 h]; Road Works Crew [52 h]; Operator - Loader [26 h]; Driver - Dump Truck [78 h]; Operator - Grader [26 h]; Operator - Roller (25 Ton) [26 h]; Driver - Water Tanker [52 h]; Driver - Fuel Tanker [26 h]; Drivers Light Duty [26 h]; Loader [28 h]; Dump Truck [84 h]; Grader [28 h]; Bobcat [28 h]; Roller-Compactor (25 Ton) [56 h]; Water Tanker [56 h]; Fuel Tanker [28 h] | 55,754.65 | 1.3.3.70 | CONS | CONS | ZONE-3 | ROAD |  | ROAD | ROAD-B |
| CON-Z3-UTI-RD-RB-060 |  | Laying & Compaction of Base Course | 15d | 2017-05-21 | 2017-06-07 | CON-Z3-UTI-RD-RB-050 SS+10d, PR-Z3-CW-RW-18-0080 | 72.8d | 0d | Common Labor / Helper [52 h]; Road Works Crew [52 h]; Operator - Loader [26 h]; Driver - Dump Truck [26 h]; Operator - Grader [26 h]; Driver - Water Tanker [26 h] | 37,169.77 | 1.3.3.70 | CONS | CONS | ZONE-3 | ROAD |  | ROAD | ROAD-B |
| CON-Z3-UTI-RD-RB-070 |  | Laying & Compaction of Prime Coat and Asphalt Binder Course | 12d | 2017-05-27 | 2017-06-10 | CON-Z3-UTI-RD-RB-060 SS+5d | 72.8d | 0d | Common Labor / Helper [52 h]; Road Works Crew [52 h]; Operator - Asphalt Paver [26 h]; Operator - Asphalt Compactor / Roller [26 h]; Operator - Roller (25 Ton) [26 h] | 55,754.65 | 1.3.3.70 | CONS | CONS | ZONE-3 | ROAD |  | ROAD | ROAD-B |
| CON-Z3-UTI-RD-RB-080 |  | Waering Course | 5d | 2017-06-01 | 2017-06-07 | CON-Z3-UTI-RD-RB-070 SS+5d | 72.8d | 0d | Common Labor / Helper [78 h]; Road Works Crew [52 h]; Driver - Dump Truck [26 h]; Operator - Asphalt Paver [26 h]; Operator - Roller (25 Ton) [26 h]; Dump Truck [28 h]; Asphalt Paver [28 h]; Asphalt Compactor / Roller [28 h] | 37,169.77 | 1.3.3.70 | CONS | CONS | ZONE-3 | ROAD |  | ROAD | ROAD-B |
| CON-Z3-UTI-RD-RB-090 |  | Pavement Marking | 10d | 2017-06-07 | 2017-06-19 | CON-Z3-UTI-RD-RB-080 | 72.8d | 0d | Common Labor / Helper [104 h]; Specialist Works Crew [26 h] | 18,584.88 | 1.3.3.70 | CONS | CONS | ZONE-3 | ROAD |  | ROAD | ROAD-B |
| CON-Z3-UTI-RD-RB-100 |  | Installation of Road Sings | 10d | 2017-06-19 | 2017-07-05 | CON-Z3-UTI-RD-RB-090 | 72.8d | 0d | Common Labor / Helper [78 h] | 18,584.88 | 1.3.3.70 | CONS | CONS | ZONE-3 | ROAD |  | ROAD | ROAD-B |
| CON-Z3-UTI-RD-RB-110 |  | Gravel Mulch for Buffer | 10d | 2017-07-05 | 2017-07-17 | PR-Z3-CW-CW-20-0080, CON-Z3-UTI-RD-RB-100, CON-Z3-UTI-RD-RA-110 SS | 72.8d | 2d | Common Labor / Helper [104 h]; Operator - Loader [100 h]; Driver - Dump Truck [52 h]; Operator - Bobcat [100 h]; Loader [140 h]; Dump Truck [140 h]; Bobcat [280 h]; Road Works Crew [52 h] | 18,584.88 | 1.3.3.70 | CONS | CONS | ZONE-3 | ROAD |  | ROAD | ROAD-B |

Notes:
- CON-Z3-POND-06-0010: Expenses: (New Expense Item) 27850.1
- CON-Z3-POND-06-0020: Expenses: (New Expense Item) 97475.3
- CON-Z3-POND-06-0030: Expenses: (New Expense Item) 55700.2
- CON-Z3-POND-06-0040: Expenses: (New Expense Item) 27850.1
- CON-Z3-POND-06-0050: Expenses: (New Expense Item) 69625.2
- CON-Z3-UTI-RD-RA-010: Expenses: (New Expense Item) 43364.7
- CON-Z3-UTI-RD-RA-020: Expenses: (New Expense Item) 86729.5
- CON-Z3-UTI-RD-RA-030: Expenses: (New Expense Item) 130094
- CON-Z3-UTI-RD-RA-040: Expenses: (New Expense Item) 43364.7
- CON-Z3-UTI-RD-RA-050: Expenses: (New Expense Item) 130094
- CON-Z3-UTI-RD-RA-060: Expenses: (New Expense Item) 86729.5
- CON-Z3-UTI-RD-RA-070: Expenses: (New Expense Item) 130094
- CON-Z3-UTI-RD-RA-080: Expenses: (New Expense Item) 86729.5
- CON-Z3-UTI-RD-RA-090: Expenses: (New Expense Item) 43364.7
- CON-Z3-UTI-RD-RA-100: Expenses: (New Expense Item) 43364.7
- CON-Z3-UTI-RD-RA-110: Expenses: (New Expense Item) 43364.7
- CON-Z3-UTI-RD-RB-010: Expenses: (New Expense Item) 18584.9
- CON-Z3-UTI-RD-RB-020: Expenses: (New Expense Item) 37169.8
- CON-Z3-UTI-RD-RB-030: Expenses: (New Expense Item) 55754.7
- CON-Z3-UTI-RD-RB-040: Expenses: (New Expense Item) 18584.9
- CON-Z3-UTI-RD-RB-050: Expenses: (New Expense Item) 55754.7
- CON-Z3-UTI-RD-RB-060: Expenses: (New Expense Item) 37169.8
- CON-Z3-UTI-RD-RB-070: Expenses: (New Expense Item) 55754.7
- CON-Z3-UTI-RD-RB-080: Expenses: (New Expense Item) 37169.8
- CON-Z3-UTI-RD-RB-090: Expenses: (New Expense Item) 18584.9
- CON-Z3-UTI-RD-RB-100: Expenses: (New Expense Item) 18584.9
- CON-Z3-UTI-RD-RB-110: Expenses: (New Expense Item) 18584.9

| ID | WBS | Activity | Duration | Start | Finish | Predecessors | Total float | Free float | Resources | Cost | RPI_P2 - BOQ ITEMS | RPI_P2 - CONSTRUCTION | RPI_P2 - PHASE | RPI_P2 - ZONES | RPI_P2 - AREAS | RPI_P2 - DISCIPLINE / WORK TYPE | RPI_P2 - UTILITY NETWORK |
| --- | --- | --- | --- | --- | --- | --- | --- | --- | --- | --- | --- | --- | --- | --- | --- | --- | --- |
|  | 1 | **Existing Roads (Remaining Road Works including Road Crossings)** |  | 2016-10-23 | 2017-08-03 |  |  |  |  |  |  |  |  |  |  |  |  |
|  | 1 | **Road 2** |  | 2017-03-04 | 2017-07-19 |  |  |  |  |  |  |  |  |  |  |  |  |
| CON-Z3-UTI-RD-R2-010 |  | Clearing & Grubbing | 10d | 2017-03-04 | 2017-03-15 | CON-Z3-UTI-RD-RA-010 SS+15d | 50.8d | 0d | Loader [28 h]; Grader [28 h]; Common Labor / Helper [78 h]; Operator - Loader [26 h]; Operator - Grader [26 h] | 14,423.59 | 1.3.3.70 | CONS | CONS | ZONE-3 | ROAD-2 | ROAD | ROAD |
| CON-Z3-UTI-RD-R2-020 |  | Remaining Backfilling Works (including Road Crossings) | 30d | 2017-03-07 | 2017-04-11 | CON-Z3-UTI-RD-R2-010 SS+3d | 70.8d | 0d | Common Labor / Helper [104 h]; Road Works Crew [78 h]; Operator - Loader [26 h]; Driver - Dump Truck [26 h]; Operator - Roller (25 Ton) [26 h]; Driver - Fuel Tanker [26 h]; Loader [28 h]; Dump Truck [28 h]; Bobcat [28 h]; Roller-Compactor (2~10 Ton) [28 h]; Roller-Compactor (25 Ton) [28 h]; Water Tanker [28 h] | 28,847.18 | 1.3.3.70 | CONS | CONS | ZONE-3 | ROAD-2 | ROAD | ROAD |
| CON-Z3-UTI-RD-R2-030 |  | Remaining Curbs & Gutter (including Road Crossings) | 30d | 2017-03-13 | 2017-04-17 | CON-Z3-UTI-RD-R2-020 SS+5d | 70.8d | 0d | Steel Fixer [52 h]; Shuttering Carpenter [78 h]; Concrete Mason [78 h]; Common Labor / Helper [78 h]; Driver - Conc. Transit Mixers [26 h]; Operator - Concrete Pump [26 h]; Concrete Transit Mixers [28 h]; Concrete Pump [28 h] | 43,270.76 | 1.3.3.70 | CONS | CONS | ZONE-3 | ROAD-2 | ROAD | ROAD |
| CON-Z3-UTI-RD-R2-040 |  | Remaining Laying of Geo Grid and Geotextile (including Road Crossings) | 20d | 2017-03-19 | 2017-04-11 | CON-Z3-UTI-RD-R2-030 SS+5d, PR-Z3-CW-CW-22-0080 | 70.8d | 0d | Common Labor / Helper [78 h]; Road Works Crew [52 h] | 14,423.59 | 1.3.3.70 | CONS | CONS | ZONE-3 | ROAD-2 | ROAD | ROAD |
| CON-Z3-UTI-RD-R2-050 |  | Remaining Laying & Compaction of Sub-Base (including Road Crossings) | 40d | 2017-03-22 | 2017-05-08 | CON-Z3-UTI-RD-R2-040 SS+3d | 70.8d | 0d | Common Labor / Helper [104 h]; Road Works Crew [52 h]; Operator - Loader [26 h]; Driver - Dump Truck [78 h]; Operator - Grader [26 h]; Operator - Roller (25 Ton) [26 h]; Driver - Water Tanker [52 h]; Driver - Fuel Tanker [26 h]; Drivers Light Duty [26 h]; Loader [28 h]; Dump Truck [84 h]; Grader [28 h]; Bobcat [28 h]; Roller-Compactor (25 Ton) [56 h]; Water Tanker [56 h]; Fuel Tanker [28 h] | 43,270.76 | 1.3.3.70 | CONS | CONS | ZONE-3 | ROAD-2 | ROAD | ROAD |
| CON-Z3-UTI-RD-R2-060 |  | Remaining Laying & Compaction of Base Course (including Road Crossings) | 30d | 2017-04-30 | 2017-06-04 | CON-Z3-UTI-RD-R2-050 SS+33d | 70.8d | 0d | Common Labor / Helper [52 h]; Road Works Crew [300 h]; Operator - Loader [300 h]; Driver - Dump Truck [300 h]; Operator - Grader [300 h]; Driver - Water Tanker [300 h] | 28,847.18 | 1.3.3.70 | CONS | CONS | ZONE-3 | ROAD-2 | ROAD | ROAD |
| CON-Z3-UTI-RD-R2-070 |  | Remaining Laying & Compaction of Prime Coat and Asphalt Binder Course (including Road Crossings) | 25d | 2017-05-06 | 2017-06-04 | CON-Z3-UTI-RD-R2-060 SS+5d | 70.8d | 0d | Common Labor / Helper [52 h]; Road Works Crew [250 h]; Operator - Asphalt Paver [250 h]; Operator - Asphalt Compactor / Roller [250 h]; Operator - Roller (25 Ton) [250 h] | 43,270.76 | 1.3.3.70 | CONS | CONS | ZONE-3 | ROAD-2 | ROAD | ROAD |
| CON-Z3-UTI-RD-R2-080 |  | Remaining Waering Course (including Road Crossings) | 10d | 2017-05-11 | 2017-05-23 | CON-Z3-UTI-RD-R2-070 SS+5d | 70.8d | 0d | Common Labor / Helper [78 h]; Road Works Crew [52 h]; Driver - Dump Truck [100 h]; Operator - Asphalt Paver [100 h]; Operator - Roller (25 Ton) [100 h]; Dump Truck [140 h]; Asphalt Paver [140 h]; Asphalt Compactor / Roller [140 h] | 28,847.18 | 1.3.3.70 | CONS | CONS | ZONE-3 | ROAD-2 | ROAD | ROAD |
| CON-Z3-UTI-RD-R2-090 |  | Remaining Pavement Marking (including Road Crossings) | 15d | 2017-05-23 | 2017-06-10 | CON-Z3-UTI-RD-R2-080 | 70.8d | 0d | Common Labor / Helper [104 h]; Specialist Works Crew [26 h] | 14,423.59 | 1.3.3.70 | CONS | CONS | ZONE-3 | ROAD-2 | ROAD | ROAD |
| CON-Z3-UTI-RD-R2-100 |  | Installation of Road Sings | 20d | 2017-06-10 | 2017-07-08 | CON-Z3-UTI-RD-R2-090 | 70.8d | 0d | Common Labor / Helper [78 h] | 14,423.59 | 1.3.3.70 | CONS | CONS | ZONE-3 | ROAD-2 | ROAD | ROAD |
| CON-Z3-UTI-RD-R2-110 |  | Gravel Mulch for Buffer | 10d | 2017-07-08 | 2017-07-19 | CON-Z3-UTI-RD-RB-110 SS, CON-Z3-UTI-RD-R2-100 | 70.8d | 3d | Common Labor / Helper [104 h]; Road Works Crew [200 h]; Operator - Loader [100 h]; Driver - Dump Truck [52 h]; Operator - Bobcat [100 h]; Loader [140 h]; Dump Truck [140 h]; Bobcat [280 h] | 14,423.59 | 1.3.3.70 | CONS | CONS | ZONE-3 | ROAD-2 | ROAD | ROAD |
|  | 2 | **Road 3** |  | 2017-03-15 | 2017-08-03 |  |  |  |  |  |  |  |  |  |  |  |  |
| CON-Z3-UTI-RD-R3-010 |  | Clearing & Grubbing | 12d | 2017-03-15 | 2017-03-29 | CON-Z3-UTI-RD-R2-010 | 50.8d | 0d | Common Labor / Helper [78 h]; Operator - Loader [26 h]; Operator - Grader [26 h]; Loader [28 h]; Grader [28 h] | 16,827.52 | 1.3.3.70 | CONS | CONS | ZONE-3 | ROAD-3 | ROAD | ROAD |
| CON-Z3-UTI-RD-R3-020 |  | Remaining Backfilling Works (including Road Crossings) | 35d | 2017-03-19 | 2017-04-29 | CON-Z3-UTI-RD-R3-010 SS+3d | 67.8d | 0d | Common Labor / Helper [104 h]; Road Works Crew [78 h]; Operator - Loader [26 h]; Driver - Dump Truck [26 h]; Operator - Roller (25 Ton) [26 h]; Driver - Fuel Tanker [26 h]; Loader [28 h]; Dump Truck [28 h]; Bobcat [28 h]; Roller-Compactor (2~10 Ton) [28 h]; Roller-Compactor (25 Ton) [28 h]; Water Tanker [28 h] | 33,655.04 | 1.3.3.70 | CONS | CONS | ZONE-3 | ROAD-3 | ROAD | ROAD |
| CON-Z3-UTI-RD-R3-030 |  | Remaining Curbs & Gutter (including Road Crossings) | 35d | 2017-03-25 | 2017-05-04 | CON-Z3-UTI-RD-R3-020 SS+5d | 67.8d | 0d | Steel Fixer [52 h]; Shuttering Carpenter [78 h]; Concrete Mason [78 h]; Common Labor / Helper [78 h]; Driver - Conc. Transit Mixers [26 h]; Operator - Concrete Pump [26 h]; Concrete Transit Mixers [28 h]; Concrete Pump [28 h] | 50,482.56 | 1.3.3.70 | CONS | CONS | ZONE-3 | ROAD-3 | ROAD | ROAD |
| CON-Z3-UTI-RD-R3-040 |  | Remaining Laying of Geo Grid and Geotextile (including Road Crossings) | 25d | 2017-04-30 | 2017-05-29 | CON-Z3-UTI-RD-R3-030 SS+31d | 67.8d | 0d | Common Labor / Helper [78 h]; Road Works Crew [250 h] | 16,827.52 | 1.3.3.70 | CONS | CONS | ZONE-3 | ROAD-3 | ROAD | ROAD |
| CON-Z3-UTI-RD-R3-050 |  | Remaining Laying & Compaction of Sub-Base (including Road Crossings) | 45d | 2017-05-03 | 2017-06-25 | CON-Z3-UTI-RD-R3-040 SS+3d | 67.8d | 0d | Operator - Roller (25 Ton) [450 h]; Driver - Water Tanker [450 h]; Driver - Fuel Tanker [450 h]; Drivers Light Duty [450 h]; Loader [630 h]; Dump Truck [630 h]; Grader [630 h]; Bobcat [630 h]; Roller-Compactor (25 Ton) [630 h]; Water Tanker [630 h]; Fuel Tanker [630 h]; Common Labor / Helper [104 h]; Road Works Crew [450 h]; Operator - Loader [450 h]; Driver - Dump Truck [450 h]; Operator - Grader [450 h] | 50,482.56 | 1.3.3.70 | CONS | CONS | ZONE-3 | ROAD-3 | ROAD | ROAD |
| CON-Z3-UTI-RD-R3-060 |  | Remaining Laying & Compaction of Base Course (including Road Crossings) | 35d | 2017-05-15 | 2017-06-25 | CON-Z3-UTI-RD-R3-050 SS+10d | 67.8d | 0d | Common Labor / Helper [52 h]; Road Works Crew [52 h]; Operator - Loader [26 h]; Driver - Dump Truck [26 h]; Operator - Grader [26 h]; Driver - Water Tanker [26 h] | 33,655.04 | 1.3.3.70 | CONS | CONS | ZONE-3 | ROAD-3 | ROAD | ROAD |
| CON-Z3-UTI-RD-R3-070 |  | Remaining Laying & Compaction of Prime Coat and Asphalt Binder Course (including Road Crossings) | 30d | 2017-05-21 | 2017-06-25 | CON-Z3-UTI-RD-R3-060 SS+5d | 67.8d | 0d | Common Labor / Helper [52 h]; Road Works Crew [52 h]; Operator - Asphalt Paver [26 h]; Operator - Asphalt Compactor / Roller [26 h]; Operator - Roller (25 Ton) [26 h] | 50,482.56 | 1.3.3.70 | CONS | CONS | ZONE-3 | ROAD-3 | ROAD | ROAD |
| CON-Z3-UTI-RD-R3-080 |  | Remaining Waering Course (including Road Crossings) | 15d | 2017-05-27 | 2017-06-13 | CON-Z3-UTI-RD-R3-070 SS+5d | 67.8d | 0d | Operator - Roller (25 Ton) [26 h]; Dump Truck [28 h]; Asphalt Paver [28 h]; Asphalt Compactor / Roller [28 h]; Common Labor / Helper [78 h]; Road Works Crew [52 h]; Driver - Dump Truck [26 h]; Operator - Asphalt Paver [26 h] | 33,655.04 | 1.3.3.70 | CONS | CONS | ZONE-3 | ROAD-3 | ROAD | ROAD |
| CON-Z3-UTI-RD-R3-090 |  | Remaining Pavement Marking (including Road Crossings) | 20d | 2017-06-13 | 2017-07-11 | CON-Z3-UTI-RD-R3-080 | 67.8d | 0d | Common Labor / Helper [104 h]; Specialist Works Crew [26 h] | 16,827.52 | 1.3.3.70 | CONS | CONS | ZONE-3 | ROAD-3 | ROAD | ROAD |
| CON-Z3-UTI-RD-R3-100 |  | Installation of Road Sings | 20d | 2017-07-11 | 2017-08-03 | CON-Z3-UTI-RD-R3-090 | 67.8d | 0d | Common Labor / Helper [600 h] | 16,827.52 | 1.3.3.70 | CONS | CONS | ZONE-3 | ROAD-3 | ROAD | ROAD |
| CON-Z3-UTI-RD-R3-110 |  | Gravel Mulch for Buffer | 12d | 2017-07-11 | 2017-07-25 | CON-Z3-UTI-RD-R2-110 SS, CON-Z3-UTI-RD-R3-100 SS | 67.8d | 3d | Common Labor / Helper [104 h]; Road Works Crew [120 h]; Operator - Loader [120 h]; Driver - Dump Truck [120 h]; Operator - Bobcat [240 h]; Loader [168 h]; Dump Truck [168 h]; Bobcat [336 h] | 16,827.52 | 1.3.3.70 | CONS | CONS | ZONE-3 | ROAD-3 | ROAD | ROAD |

Notes:
- CON-Z3-UTI-RD-R2-010: Expenses: (New Expense Item) 14423.6
- CON-Z3-UTI-RD-R2-020: Expenses: (New Expense Item) 28847.2
- CON-Z3-UTI-RD-R2-030: Expenses: (New Expense Item) 43270.8
- CON-Z3-UTI-RD-R2-040: Expenses: (New Expense Item) 14423.6
- CON-Z3-UTI-RD-R2-050: Expenses: (New Expense Item) 43270.8
- CON-Z3-UTI-RD-R2-060: Expenses: (New Expense Item) 28847.2
- CON-Z3-UTI-RD-R2-070: Expenses: (New Expense Item) 43270.8
- CON-Z3-UTI-RD-R2-080: Expenses: (New Expense Item) 28847.2
- CON-Z3-UTI-RD-R2-090: Expenses: (New Expense Item) 14423.6
- CON-Z3-UTI-RD-R2-100: Expenses: (New Expense Item) 14423.6
- CON-Z3-UTI-RD-R2-110: Expenses: (New Expense Item) 14423.6
- CON-Z3-UTI-RD-R3-010: Expenses: (New Expense Item) 16827.5
- CON-Z3-UTI-RD-R3-020: Expenses: (New Expense Item) 33655
- CON-Z3-UTI-RD-R3-030: Expenses: (New Expense Item) 50482.6
- CON-Z3-UTI-RD-R3-040: Expenses: (New Expense Item) 16827.5
- CON-Z3-UTI-RD-R3-050: Expenses: (New Expense Item) 50482.6
- CON-Z3-UTI-RD-R3-060: Expenses: (New Expense Item) 33655
- CON-Z3-UTI-RD-R3-070: Expenses: (New Expense Item) 50482.6
- CON-Z3-UTI-RD-R3-080: Expenses: (New Expense Item) 33655
- CON-Z3-UTI-RD-R3-090: Expenses: (New Expense Item) 16827.5
- CON-Z3-UTI-RD-R3-100: Expenses: (New Expense Item) 16827.5
- CON-Z3-UTI-RD-R3-110: Expenses: (New Expense Item) 16827.5

| ID | WBS | Activity | Duration | Start | Finish | Predecessors | Total float | Free float | Resources | Cost | RPI_P2 - BOQ ITEMS | RPI_P2 - CONSTRUCTION | RPI_P2 - PHASE | RPI_P2 - ZONES | RPI_P2 - AREAS | RPI_P2 - DISCIPLINE / WORK TYPE | RPI_P2 - UTILITY NETWORK | RPI_P2 - CROSSINGS |
| --- | --- | --- | --- | --- | --- | --- | --- | --- | --- | --- | --- | --- | --- | --- | --- | --- | --- | --- |
|  | 3 | **Road 4** |  | 2017-03-29 | 2017-07-26 |  |  |  |  |  |  |  |  |  |  |  |  |  |
| CON-Z3-UTI-RD-R4-010 |  | Clearing & Grubbing | 5d | 2017-03-29 | 2017-04-04 | CON-Z3-UTI-RD-R3-010 | 50.8d | 0d | Common Labor / Helper [78 h]; Operator - Loader [26 h]; Operator - Grader [26 h]; Loader [28 h]; Grader [28 h] | 7,211.79 | 1.3.3.70 | CONS | CONS | ZONE-3 | ROAD-4 | ROAD | ROAD |  |
| CON-Z3-UTI-RD-R4-020 |  | Remaining Backfilling Works (including Road Crossings) | 20d | 2017-05-03 | 2017-05-27 | CON-Z3-UTI-RD-R4-010 SS+30d | 50.8d | 0d | Common Labor / Helper [104 h]; Road Works Crew [78 h]; Operator - Loader [26 h]; Driver - Dump Truck [26 h]; Operator - Roller (25 Ton) [26 h]; Driver - Fuel Tanker [26 h]; Loader [28 h]; Dump Truck [28 h]; Bobcat [28 h]; Roller-Compactor (2~10 Ton) [28 h]; Roller-Compactor (25 Ton) [28 h]; Water Tanker [28 h] | 14,423.59 | 1.3.3.70 | CONS | CONS | ZONE-3 | ROAD-4 | ROAD | ROAD |  |
| CON-Z3-UTI-RD-R4-030 |  | Remaining Curbs & Gutter (including Road Crossings) | 25d | 2017-05-09 | 2017-06-07 | CON-Z3-UTI-RD-R4-020 SS+5d | 50.8d | 0d | Steel Fixer [52 h]; Shuttering Carpenter [78 h]; Concrete Mason [78 h]; Common Labor / Helper [78 h]; Driver - Conc. Transit Mixers [26 h]; Operator - Concrete Pump [26 h]; Concrete Transit Mixers [28 h]; Concrete Pump [28 h] | 21,635.38 | 1.3.3.70 | CONS | CONS | ZONE-3 | ROAD-4 | ROAD | ROAD |  |
| CON-Z3-UTI-RD-R4-040 |  | Remaining Laying of Geo Grid and Geotextile (including Road Crossings) | 10d | 2017-05-15 | 2017-05-27 | CON-Z3-UTI-RD-R4-030 SS+5d | 50.8d | 0d | Common Labor / Helper [78 h]; Road Works Crew [52 h] | 7,211.79 | 1.3.3.70 | CONS | CONS | ZONE-3 | ROAD-4 | ROAD | ROAD |  |
| CON-Z3-UTI-RD-R4-050 |  | Remaining Laying & Compaction of Sub-Base (including Road Crossings) | 20d | 2017-05-18 | 2017-06-11 | CON-Z3-UTI-RD-R4-040 SS+3d | 50.8d | 0d | Common Labor / Helper [104 h]; Road Works Crew [52 h]; Operator - Loader [26 h]; Driver - Dump Truck [78 h]; Operator - Grader [26 h]; Operator - Roller (25 Ton) [26 h]; Driver - Water Tanker [52 h]; Driver - Fuel Tanker [26 h]; Drivers Light Duty [26 h]; Loader [28 h]; Dump Truck [84 h]; Grader [28 h]; Bobcat [28 h]; Roller-Compactor (25 Ton) [56 h]; Water Tanker [56 h]; Fuel Tanker [28 h] | 21,635.38 | 1.3.3.70 | CONS | CONS | ZONE-3 | ROAD-4 | ROAD | ROAD |  |
| CON-Z3-UTI-RD-R4-060 |  | Remaining Laying & Compaction of Base Course (including Road Crossings) | 15d | 2017-05-30 | 2017-06-17 | CON-Z3-UTI-RD-R4-050 SS+10d | 50.8d | 0d | Common Labor / Helper [52 h]; Road Works Crew [52 h]; Operator - Loader [26 h]; Driver - Dump Truck [26 h]; Operator - Grader [26 h]; Driver - Water Tanker [26 h] | 14,423.59 | 1.3.3.70 | CONS | CONS | ZONE-3 | ROAD-4 | ROAD | ROAD |  |
| CON-Z3-UTI-RD-R4-070 |  | Remaining Laying & Compaction of Prime Coat and Asphalt Binder Course (including Road Crossings) | 5d | 2017-06-05 | 2017-06-11 | CON-Z3-UTI-RD-R4-060 SS+5d | 50.8d | 0d | Common Labor / Helper [52 h]; Road Works Crew [52 h]; Operator - Asphalt Paver [26 h]; Operator - Asphalt Compactor / Roller [26 h]; Operator - Roller (25 Ton) [26 h] | 21,635.38 | 1.3.3.70 | CONS | CONS | ZONE-3 | ROAD-4 | ROAD | ROAD |  |
| CON-Z3-UTI-RD-R4-080 |  | Remaining Waering Course (including Road Crossings) | 15d | 2017-06-11 | 2017-07-03 | CON-Z3-UTI-RD-R4-070 SS+5d | 50.8d | 0d | Common Labor / Helper [78 h]; Road Works Crew [52 h]; Driver - Dump Truck [26 h]; Operator - Asphalt Paver [26 h]; Operator - Roller (25 Ton) [26 h]; Dump Truck [28 h]; Asphalt Paver [28 h]; Asphalt Compactor / Roller [28 h] | 14,423.59 | 1.3.3.70 | CONS | CONS | ZONE-3 | ROAD-4 | ROAD | ROAD |  |
| CON-Z3-UTI-RD-R4-090 |  | Remaining Pavement Marking (including Road Crossings) | 10d | 2017-07-03 | 2017-07-15 | CON-Z3-UTI-RD-R4-080 | 64.8d | 0d | Common Labor / Helper [104 h]; Specialist Works Crew [100 h] | 7,211.79 | 1.3.3.70 | CONS | CONS | ZONE-3 | ROAD-4 | ROAD | ROAD |  |
| CON-Z3-UTI-RD-R4-100 |  | Installation of Road Sings | 10d | 2017-07-15 | 2017-07-26 | CON-Z3-UTI-RD-R4-090 | 64.8d | 0d | Common Labor / Helper [78 h] | 7,211.79 | 1.3.3.70 | CONS | CONS | ZONE-3 | ROAD-4 | ROAD | ROAD |  |
| CON-Z3-UTI-RD-R4-120 |  | Gravel Mulch for Buffer | 10d | 2017-07-15 | 2017-07-26 | CON-Z3-UTI-RD-R4-100 SS, CON-Z3-UTI-RD-R3-110 SS | 64.8d | 7.6d | Common Labor / Helper [104 h]; Road Works Crew [52 h]; Operator - Loader [100 h]; Driver - Dump Truck [52 h]; Operator - Bobcat [200 h]; Loader [140 h]; Dump Truck [140 h]; Bobcat [280 h] | 7,211.79 | 1.3.3.70 | CONS | CONS | ZONE-3 | ROAD-4 | ROAD | ROAD |  |
|  | 4 | **Road 5 Crossing** |  | 2016-10-23 | 2017-04-19 |  |  |  |  |  |  |  |  |  |  |  |  |  |
|  | 1 | **Part -1 of One Side of Road** |  | 2016-10-23 | 2016-12-19 |  |  |  |  |  |  |  |  |  |  |  |  |  |
| CON-Z3-UTI-RD-R5-010 |  | Security / Work Permits & Other Requirements | 12d | 2016-10-23 | 2016-11-06 | CON-CON-CON-CON-0010 FS+60d | 134.8d | 0d | Common Labor / Helper [78 h] | 432.71 | 1.3.3.70 | CONS | CONS | ZONE-3 | ROAD-5 | ROAD | ROAD | ROAD-5 XING |
| CON-Z3-UTI-RD-R5-020 |  | Safety Arrangements and Traffic Diversion | 2.4d | 2016-11-06 | 2016-11-08 | CON-Z3-UTI-RD-R5-010 | 144.2d | 0d |  | 1,081.77 | 1.3.3.70 | CONS | CONS | ZONE-3 | ROAD-5 | ROAD | ROAD | ROAD-5 XING |
| CON-Z3-UTI-RD-R5-030 |  | Relocation of Jersy Barriers | 1.6d | 2016-11-08 | 2016-11-10 | CON-Z3-UTI-RD-R5-020 | 144.2d | 0d | Common Labor / Helper [78 h]; Operator - Mobile Crane [26 h]; Mobile Crane ( 25-60 Ton) [28 h] | 649.06 | 1.3.3.70 | CONS | CONS | ZONE-3 | ROAD-5 | ROAD | ROAD | ROAD-5 XING |
| CON-Z3-UTI-RD-R5-040 |  | Removal of Asphalt | 2.4d | 2016-11-10 | 2016-11-13 | CON-Z3-UTI-RD-R5-030 | 144.2d | 0d | Common Labor / Helper [26 h]; Operator - Excavator [26 h]; Excavator [28 h] | 1,081.77 | 1.3.3.70 | CONS | CONS | ZONE-3 | ROAD-5 | ROAD | ROAD | ROAD-5 XING |
| CON-Z3-UTI-RD-R5-050 |  | Hand Excavation | 6.4d | 2016-11-13 | 2016-11-20 | CON-Z3-UTI-RD-R5-040 | 144.2d | 0d | Common Labor / Helper [156 h] | 3,245.31 | 1.3.3.70 | CONS | CONS | ZONE-3 | ROAD-5 | ROAD | ROAD | ROAD-5 XING |
| CON-Z3-UTI-RD-R5-060 |  | Installation of Sleeves for Potable Water Lines | 2.4d | 2016-11-21 | 2016-11-23 | CON-Z3-UTI-RD-R5-050 | 144.2d | 0d | Plumber [124.8 h]; Welder [26 h]; Common Labor / Helper [124.8 h]; RTR Pipe Crew [31.2 h]; Operator - Forklift [26 h]; Operator - Mobile Crane [26 h]; Forklift [33.6 h]; Mobile Crane ( 25-60 Ton) [28 h] | 1,081.77 | 1.3.3.70 | CONS | CONS | ZONE-3 | ROAD-5 | ROAD | ROAD | ROAD-5 XING |
| CON-Z3-UTI-RD-R5-070 |  | Installation of Sleeves for Sea Water Lines | 2.4d | 2016-11-23 | 2016-11-26 | CON-Z3-UTI-RD-R5-060 | 144.2d | 0d | Plumber [52 h]; Welder [26 h]; Common Labor / Helper [52 h]; RTR Pipe Crew [26 h]; Operator - Forklift [26 h]; Operator - Mobile Crane [26 h]; Forklift [28 h]; Mobile Crane ( 25-60 Ton) [28 h] | 1,081.77 | 1.3.3.70 | CONS | CONS | ZONE-3 | ROAD-5 | ROAD | ROAD | ROAD-5 XING |
| CON-Z3-UTI-RD-R5-080 |  | Instalaltion of Sleeves for Sewer Force Mains | 2.4d | 2016-11-26 | 2016-11-29 | CON-Z3-UTI-RD-R5-070 | 144.2d | 0d | Plumber [93.6 h]; Common Labor / Helper [124.8 h]; Operator - Mobile Crane [26 h]; Mobile Crane ( 25-60 Ton) [28 h] | 1,081.77 | 1.3.3.70 | CONS | CONS | ZONE-3 | ROAD-5 | ROAD | ROAD | ROAD-5 XING |
| CON-Z3-UTI-RD-R5-090 |  | Instalaltion of Sleeves for Electrical Cables | 2.4d | 2016-11-29 | 2016-12-01 | CON-Z3-UTI-RD-R5-080 | 144.2d | 0d | Plumber [93.6 h]; Common Labor / Helper [124.8 h]; Operator - Mobile Crane [31.2 h]; Mobile Crane ( 25-60 Ton) [33.6 h] | 1,081.77 | 1.3.3.70 | CONS | CONS | ZONE-3 | ROAD-5 | ROAD | ROAD | ROAD-5 XING |
| CON-Z3-UTI-RD-R5-100 |  | Sandfilling | 1.6d | 2016-12-01 | 2016-12-04 | CON-Z3-UTI-RD-R5-090 | 144.2d | 0d | Common Labor / Helper [78 h]; Operator - Bobcat [26 h]; Driver - Water Tanker [26 h]; Operator - JCB [26 h]; Bobcat [28 h]; Water Tanker [28 h]; JCB [28 h] | 1,081.77 | 1.3.3.70 | CONS | CONS | ZONE-3 | ROAD-5 | ROAD | ROAD | ROAD-5 XING |
| CON-Z3-UTI-RD-R5-110 |  | Final Backfilling | 4d | 2016-12-04 | 2016-12-08 | CON-Z3-UTI-RD-R5-100 | 144.2d | 0d | Operator - Roller (25 Ton) [26 h]; Driver - Fuel Tanker [26 h]; Loader [28 h]; Dump Truck [28 h]; Bobcat [28 h]; Roller-Compactor (2~10 Ton) [28 h]; Roller-Compactor (25 Ton) [28 h]; Water Tanker [28 h]; Common Labor / Helper [104 h]; Road Works Crew [78 h]; Operator - Loader [26 h]; Driver - Dump Truck [26 h] | 1,081.77 | 1.3.3.70 | CONS | CONS | ZONE-3 | ROAD-5 | ROAD | ROAD | ROAD-5 XING |
| CON-Z3-UTI-RD-R5-120 |  | Sub Base Course | 4d | 2016-12-08 | 2016-12-13 | CON-Z3-UTI-RD-R5-110 | 144.2d | 0d | Common Labor / Helper [52 h]; Road Works Crew [52 h]; Operator - Loader [26 h]; Driver - Dump Truck [26 h]; Operator - Grader [26 h]; Driver - Water Tanker [26 h] | 2,163.54 | 1.3.3.70 | CONS | CONS | ZONE-3 | ROAD-5 | ROAD | ROAD | ROAD-5 XING |
| CON-Z3-UTI-RD-R5-130 |  | Base Course | 2.4d | 2016-12-13 | 2016-12-15 | CON-Z3-UTI-RD-R5-120 | 144.2d | 0d | Common Labor / Helper [52 h]; Road Works Crew [52 h]; Operator - Loader [26 h]; Driver - Dump Truck [26 h]; Operator - Grader [26 h]; Driver - Water Tanker [26 h] | 1,081.77 | 1.3.3.70 | CONS | CONS | ZONE-3 | ROAD-5 | ROAD | ROAD | ROAD-5 XING |
| CON-Z3-UTI-RD-R5-140 |  | Asphalt Work | 0.8d | 2016-12-15 | 2016-12-17 | CON-Z3-UTI-RD-R5-130 | 144.2d | 0d | Common Labor / Helper [52 h]; Road Works Crew [52 h]; Operator - Asphalt Paver [26 h]; Operator - Asphalt Compactor / Roller [26 h]; Operator - Roller (25 Ton) [26 h] | 3,245.31 | 1.3.3.70 | CONS | CONS | ZONE-3 | ROAD-5 | ROAD | ROAD | ROAD-5 XING |
| CON-Z3-UTI-RD-R5-150 |  | Wearing Course | 0.8d | 2016-12-17 | 2016-12-18 | CON-Z3-UTI-RD-R5-140 | 144.2d | 0d | Common Labor / Helper [52 h]; Road Works Crew [52 h]; Operator - Asphalt Paver [26 h]; Operator - Asphalt Compactor / Roller [26 h]; Asphalt Paver [28 h]; Asphalt Compactor / Roller [28 h] | 1,081.77 | 1.3.3.70 | CONS | CONS | ZONE-3 | ROAD-5 | ROAD | ROAD | ROAD-5 XING |
| CON-Z3-UTI-RD-R5-160 |  | Road Marking | 0.8d | 2016-12-18 | 2016-12-18 | CON-Z3-UTI-RD-R5-150 | 144.2d | 0d | Common Labor / Helper [104 h] | 649.06 | 1.3.3.70 | CONS | CONS | ZONE-3 | ROAD-5 | ROAD | ROAD | ROAD-5 XING |
| CON-Z3-UTI-RD-R5-170 |  | Road Opening for Traffic | 0.8d | 2016-12-19 | 2016-12-19 | CON-Z3-UTI-RD-R5-160 | 144.2d | 0d | Common Labor / Helper [52 h] | 432.71 | 1.3.3.70 | CONS | CONS | ZONE-3 | ROAD-5 | ROAD | ROAD | ROAD-5 XING |

Notes:
- CON-Z3-UTI-RD-R4-010: Expenses: (New Expense Item) 7211.79
- CON-Z3-UTI-RD-R4-020: Expenses: (New Expense Item) 14423.6
- CON-Z3-UTI-RD-R4-030: Expenses: (New Expense Item) 21635.4
- CON-Z3-UTI-RD-R4-040: Expenses: (New Expense Item) 7211.79
- CON-Z3-UTI-RD-R4-050: Expenses: (New Expense Item) 21635.4
- CON-Z3-UTI-RD-R4-060: Expenses: (New Expense Item) 14423.6
- CON-Z3-UTI-RD-R4-070: Expenses: (New Expense Item) 21635.4
- CON-Z3-UTI-RD-R4-080: Expenses: (New Expense Item) 14423.6
- CON-Z3-UTI-RD-R4-090: Expenses: (New Expense Item) 7211.79
- CON-Z3-UTI-RD-R4-100: Expenses: (New Expense Item) 7211.79
- CON-Z3-UTI-RD-R4-120: Expenses: (New Expense Item) 7211.79
- CON-Z3-UTI-RD-R5-010: Expenses: (New Expense Item) 432.71
- CON-Z3-UTI-RD-R5-020: Expenses: (New Expense Item) 1081.77
- CON-Z3-UTI-RD-R5-030: Expenses: (New Expense Item) 649.06
- CON-Z3-UTI-RD-R5-040: Expenses: (New Expense Item) 1081.77
- CON-Z3-UTI-RD-R5-050: Expenses: (New Expense Item) 3245.31
- CON-Z3-UTI-RD-R5-060: Expenses: (New Expense Item) 1081.77
- CON-Z3-UTI-RD-R5-070: Expenses: (New Expense Item) 1081.77
- CON-Z3-UTI-RD-R5-080: Expenses: (New Expense Item) 1081.77
- CON-Z3-UTI-RD-R5-090: Expenses: (New Expense Item) 1081.77
- CON-Z3-UTI-RD-R5-100: Expenses: (New Expense Item) 1081.77
- CON-Z3-UTI-RD-R5-110: Expenses: (New Expense Item) 1081.77
- CON-Z3-UTI-RD-R5-120: Expenses: (New Expense Item) 2163.54
- CON-Z3-UTI-RD-R5-130: Expenses: (New Expense Item) 1081.77
- CON-Z3-UTI-RD-R5-140: Expenses: (New Expense Item) 3245.31
- CON-Z3-UTI-RD-R5-150: Expenses: (New Expense Item) 1081.77
- CON-Z3-UTI-RD-R5-160: Expenses: (New Expense Item) 649.06
- CON-Z3-UTI-RD-R5-170: Expenses: (New Expense Item) 432.71

| ID | WBS | Activity | Duration | Start | Finish | Predecessors | Total float | Free float | Resources | Cost | RPI_P2 - BOQ ITEMS | RPI_P2 - CONSTRUCTION | RPI_P2 - PHASE | RPI_P2 - ZONES | RPI_P2 - AREAS | RPI_P2 - DISCIPLINE / WORK TYPE | RPI_P2 - CROSSINGS | RPI_P2 - UTILITY NETWORK |
| --- | --- | --- | --- | --- | --- | --- | --- | --- | --- | --- | --- | --- | --- | --- | --- | --- | --- | --- |
|  | 2 | **Part -2 of One Side of Road** |  | 2016-12-19 | 2017-01-28 |  |  |  |  |  |  |  |  |  |  |  |  |  |
| CON-Z3-UTI-RD-R5-210 |  | Removal of Asphalt | 2.4d | 2016-12-19 | 2016-12-22 | CON-Z3-UTI-RD-R5-170 | 144.2d | 0d | Common Labor / Helper [26 h]; Operator - Excavator [26 h] | 1,081.77 | 1.3.3.70 | CONS | CONS | ZONE-3 | ROAD-5 | ROAD | ROAD-5 XING | ROAD |
| CON-Z3-UTI-RD-R5-220 |  | Hand Excavation | 6.4d | 2016-12-22 | 2016-12-29 | CON-Z3-UTI-RD-R5-210 | 144.2d | 0d | Common Labor / Helper [156 h] | 4,327.08 | 1.3.3.70 | CONS | CONS | ZONE-3 | ROAD-5 | ROAD | ROAD-5 XING | ROAD |
| CON-Z3-UTI-RD-R5-230 |  | Installation of Sleeves for Potable Water Lines | 2.4d | 2016-12-29 | 2017-01-01 | CON-Z3-UTI-RD-R5-220 | 144.2d | 0d | Plumber [52 h]; Welder [26 h]; Common Labor / Helper [52 h]; RTR Pipe Crew [26 h]; Operator - Forklift [26 h]; Operator - Mobile Crane [26 h]; Forklift [28 h]; Mobile Crane ( 25-60 Ton) [28 h] | 1,081.77 | 1.3.3.70 | CONS | CONS | ZONE-3 | ROAD-5 | ROAD | ROAD-5 XING | ROAD |
| CON-Z3-UTI-RD-R5-240 |  | Installation of Sleeves for Sea Water Lines | 2.4d | 2017-01-02 | 2017-01-04 | CON-Z3-UTI-RD-R5-230 | 144.2d | 0d | Plumber [52 h]; Welder [26 h]; Common Labor / Helper [52 h]; RTR Pipe Crew [26 h]; Operator - Forklift [26 h]; Operator - Mobile Crane [26 h]; Forklift [28 h]; Mobile Crane ( 25-60 Ton) [28 h] | 1,081.77 | 1.3.3.70 | CONS | CONS | ZONE-3 | ROAD-5 | ROAD | ROAD-5 XING | ROAD |
| CON-Z3-UTI-RD-R5-250 |  | Instalaltion of Sleeves for Sewer Force Mains | 2.4d | 2017-01-04 | 2017-01-07 | CON-Z3-UTI-RD-R5-240 | 144.2d | 0d | Common Labor / Helper [78 h]; Operator - Mobile Crane [26 h]; Mobile Crane ( 25-60 Ton) [28 h]; Plumber [52 h] | 1,081.77 | 1.3.3.70 | CONS | CONS | ZONE-3 | ROAD-5 | ROAD | ROAD-5 XING | ROAD |
| CON-Z3-UTI-RD-R5-260 |  | Instalaltion of Sleeves for Electrical Cables | 2.4d | 2017-01-07 | 2017-01-10 | CON-Z3-UTI-RD-R5-250 | 144.2d | 0d | Plumber [52 h]; Common Labor / Helper [78 h]; Operator - Mobile Crane [26 h]; Mobile Crane ( 25-60 Ton) [28 h] | 1,081.77 | 1.3.3.70 | CONS | CONS | ZONE-3 | ROAD-5 | ROAD | ROAD-5 XING | ROAD |
| CON-Z3-UTI-RD-R5-270 |  | Sandfilling | 1.6d | 2017-01-10 | 2017-01-11 | CON-Z3-UTI-RD-R5-260 | 144.2d | 0d | Common Labor / Helper [78 h]; Operator - Bobcat [26 h]; Driver - Water Tanker [26 h]; Operator - JCB [26 h]; Bobcat [28 h]; Water Tanker [28 h]; JCB [28 h] | 1,081.77 | 1.3.3.70 | CONS | CONS | ZONE-3 | ROAD-5 | ROAD | ROAD-5 XING | ROAD |
| CON-Z3-UTI-RD-R5-280 |  | Final Backfilling | 4d | 2017-01-11 | 2017-01-16 | CON-Z3-UTI-RD-R5-270 | 144.2d | 0d | Driver - Dump Truck [26 h]; Operator - Roller (25 Ton) [26 h]; Driver - Fuel Tanker [26 h]; Loader [28 h]; Dump Truck [28 h]; Bobcat [28 h]; Roller-Compactor (2~10 Ton) [28 h]; Roller-Compactor (25 Ton) [28 h]; Water Tanker [28 h]; Common Labor / Helper [104 h]; Road Works Crew [78 h]; Operator - Loader [26 h] | 1,081.77 | 1.3.3.70 | CONS | CONS | ZONE-3 | ROAD-5 | ROAD | ROAD-5 XING | ROAD |
| CON-Z3-UTI-RD-R5-290 |  | Sub Base Course | 4d | 2017-01-16 | 2017-01-21 | CON-Z3-UTI-RD-R5-280 | 144.2d | 0d | Common Labor / Helper [52 h]; Road Works Crew [52 h]; Operator - Loader [26 h]; Driver - Dump Truck [26 h]; Operator - Grader [26 h]; Driver - Water Tanker [26 h] | 2,163.54 | 1.3.3.70 | CONS | CONS | ZONE-3 | ROAD-5 | ROAD | ROAD-5 XING | ROAD |
| CON-Z3-UTI-RD-R5-300 |  | Base Course | 2.4d | 2017-01-21 | 2017-01-24 | CON-Z3-UTI-RD-R5-290 | 144.2d | 0d | Common Labor / Helper [52 h]; Road Works Crew [52 h]; Operator - Loader [26 h]; Driver - Dump Truck [26 h]; Operator - Grader [26 h]; Driver - Water Tanker [26 h] | 1,081.77 | 1.3.3.70 | CONS | CONS | ZONE-3 | ROAD-5 | ROAD | ROAD-5 XING | ROAD |
| CON-Z3-UTI-RD-R5-310 |  | Asphalt Work | 0.8d | 2017-01-24 | 2017-01-24 | CON-Z3-UTI-RD-R5-300 | 144.2d | 0d | Common Labor / Helper [52 h]; Road Works Crew [52 h]; Operator - Asphalt Paver [26 h]; Operator - Asphalt Compactor / Roller [26 h]; Operator - Roller (25 Ton) [26 h] | 3,245.31 | 1.3.3.70 | CONS | CONS | ZONE-3 | ROAD-5 | ROAD | ROAD-5 XING | ROAD |
| CON-Z3-UTI-RD-R5-320 |  | Wearing Course | 0.8d | 2017-01-25 | 2017-01-25 | CON-Z3-UTI-RD-R5-310 | 144.2d | 0d | Common Labor / Helper [52 h]; Road Works Crew [52 h]; Operator - Asphalt Paver [26 h]; Operator - Asphalt Compactor / Roller [26 h] | 2,163.54 | 1.3.3.70 | CONS | CONS | ZONE-3 | ROAD-5 | ROAD | ROAD-5 XING | ROAD |
| CON-Z3-UTI-RD-R5-330 |  | Road Marking | 0.8d | 2017-01-25 | 2017-01-26 | CON-Z3-UTI-RD-R5-320 | 144.2d | 0d | Common Labor / Helper [104 h] | 649.06 | 1.3.3.70 | CONS | CONS | ZONE-3 | ROAD-5 | ROAD | ROAD-5 XING | ROAD |
| CON-Z3-UTI-RD-R5-340 |  | Road Opening for Traffic | 0.8d | 2017-01-26 | 2017-01-28 | CON-Z3-UTI-RD-R5-330 | 144.2d | 0d | Common Labor / Helper [52 h] | 432.71 | 1.3.3.70 | CONS | CONS | ZONE-3 | ROAD-5 | ROAD | ROAD-5 XING | ROAD |
|  | 3 | **Part -1 of 2nd Side of Road** |  | 2017-01-28 | 2017-03-07 |  |  |  |  |  |  |  |  |  |  |  |  |  |
| CON-Z3-UTI-RD-R5-350 |  | Removal of Asphalt | 2.4d | 2017-01-28 | 2017-01-30 | CON-Z3-UTI-RD-R5-340 | 144.2d | 0d | Operator - Excavator [26 h]; Common Labor / Helper [26 h] | 1,081.77 | 1.3.3.70 | CONS | CONS | ZONE-3 | ROAD-5 | ROAD | ROAD-5 XING | ROAD |
| CON-Z3-UTI-RD-R5-360 |  | Hand Excavation | 6.4d | 2017-01-30 | 2017-02-07 | CON-Z3-UTI-RD-R5-350 | 144.2d | 0d | Common Labor / Helper [156 h] | 4,327.08 | 1.3.3.70 | CONS | CONS | ZONE-3 | ROAD-5 | ROAD | ROAD-5 XING | ROAD |
| CON-Z3-UTI-RD-R5-370 |  | Installation of Sleeves for Potable Water Lines | 2.4d | 2017-02-07 | 2017-02-09 | CON-Z3-UTI-RD-R5-360 | 144.2d | 0d | Plumber [52 h]; Welder [26 h]; Common Labor / Helper [52 h]; RTR Pipe Crew [26 h]; Operator - Forklift [26 h]; Operator - Mobile Crane [26 h]; Forklift [28 h]; Mobile Crane ( 25-60 Ton) [28 h] | 1,081.77 | 1.3.3.70 | CONS | CONS | ZONE-3 | ROAD-5 | ROAD | ROAD-5 XING | ROAD |
| CON-Z3-UTI-RD-R5-380 |  | Installation of Sleeves for Sea Water Lines | 2.4d | 2017-02-09 | 2017-02-12 | CON-Z3-UTI-RD-R5-370 | 144.2d | 0d | Plumber [52 h]; Welder [26 h]; Common Labor / Helper [52 h]; RTR Pipe Crew [26 h]; Operator - Forklift [26 h]; Operator - Mobile Crane [26 h]; Forklift [28 h]; Mobile Crane ( 25-60 Ton) [28 h] | 1,081.77 | 1.3.3.70 | CONS | CONS | ZONE-3 | ROAD-5 | ROAD | ROAD-5 XING | ROAD |
| CON-Z3-UTI-RD-R5-390 |  | Instalaltion of Sleeves for Sewer Force Mains | 2.4d | 2017-02-13 | 2017-02-15 | CON-Z3-UTI-RD-R5-380 | 144.2d | 0d | Plumber [52 h]; Common Labor / Helper [78 h]; Operator - Mobile Crane [26 h]; Mobile Crane ( 25-60 Ton) [28 h] | 1,081.77 | 1.3.3.70 | CONS | CONS | ZONE-3 | ROAD-5 | ROAD | ROAD-5 XING | ROAD |
| CON-Z3-UTI-RD-R5-400 |  | Instalaltion of Sleeves for Electrical Cables | 2.4d | 2017-02-15 | 2017-02-18 | CON-Z3-UTI-RD-R5-390 | 144.2d | 0d | Plumber [52 h]; Common Labor / Helper [78 h]; Operator - Mobile Crane [26 h]; Mobile Crane ( 25-60 Ton) [28 h] | 1,081.77 | 1.3.3.70 | CONS | CONS | ZONE-3 | ROAD-5 | ROAD | ROAD-5 XING | ROAD |
| CON-Z3-UTI-RD-R5-410 |  | Sandfilling | 1.6d | 2017-02-18 | 2017-02-20 | CON-Z3-UTI-RD-R5-400 | 144.2d | 0d | Common Labor / Helper [78 h]; Operator - Bobcat [26 h]; Driver - Water Tanker [26 h]; Operator - JCB [26 h]; Bobcat [28 h]; Water Tanker [28 h]; JCB [28 h] | 1,081.77 | 1.3.3.70 | CONS | CONS | ZONE-3 | ROAD-5 | ROAD | ROAD-5 XING | ROAD |
| CON-Z3-UTI-RD-R5-420 |  | Final Backfilling | 4d | 2017-02-20 | 2017-02-25 | CON-Z3-UTI-RD-R5-410 | 144.2d | 0d | Driver - Fuel Tanker [26 h]; Loader [28 h]; Dump Truck [28 h]; Bobcat [28 h]; Roller-Compactor (2~10 Ton) [28 h]; Roller-Compactor (25 Ton) [28 h]; Water Tanker [28 h]; Common Labor / Helper [104 h]; Road Works Crew [78 h]; Operator - Loader [26 h]; Driver - Dump Truck [26 h]; Operator - Roller (25 Ton) [26 h] | 1,081.77 | 1.3.3.70 | CONS | CONS | ZONE-3 | ROAD-5 | ROAD | ROAD-5 XING | ROAD |
| CON-Z3-UTI-RD-R5-430 |  | Sub Base Course | 4d | 2017-02-25 | 2017-03-01 | CON-Z3-UTI-RD-R5-420 | 144.2d | 0d | Common Labor / Helper [52 h]; Road Works Crew [52 h]; Operator - Loader [26 h]; Driver - Dump Truck [26 h]; Operator - Grader [26 h]; Driver - Water Tanker [26 h] | 2,163.54 | 1.3.3.70 | CONS | CONS | ZONE-3 | ROAD-5 | ROAD | ROAD-5 XING | ROAD |
| CON-Z3-UTI-RD-R5-440 |  | Base Course | 2.4d | 2017-03-01 | 2017-03-04 | CON-Z3-UTI-RD-R5-430 | 144.2d | 0d | Common Labor / Helper [52 h]; Road Works Crew [52 h]; Operator - Loader [26 h]; Driver - Dump Truck [26 h]; Operator - Grader [26 h]; Driver - Water Tanker [26 h] | 1,081.77 | 1.3.3.70 | CONS | CONS | ZONE-3 | ROAD-5 | ROAD | ROAD-5 XING | ROAD |
| CON-Z3-UTI-RD-R5-450 |  | Asphalt Work | 0.8d | 2017-03-04 | 2017-03-05 | CON-Z3-UTI-RD-R5-440 | 144.2d | 0d | Common Labor / Helper [52 h]; Road Works Crew [52 h]; Operator - Asphalt Paver [26 h]; Operator - Asphalt Compactor / Roller [26 h]; Operator - Roller (25 Ton) [26 h] | 3,245.31 | 1.3.3.70 | CONS | CONS | ZONE-3 | ROAD-5 | ROAD | ROAD-5 XING | ROAD |
| CON-Z3-UTI-RD-R5-460 |  | Wearing Course | 0.8d | 2017-03-05 | 2017-03-06 | CON-Z3-UTI-RD-R5-450 | 144.2d | 0d | Common Labor / Helper [52 h]; Road Works Crew [52 h]; Operator - Asphalt Paver [26 h]; Operator - Asphalt Compactor / Roller [26 h] | 2,163.54 | 1.3.3.70 | CONS | CONS | ZONE-3 | ROAD-5 | ROAD | ROAD-5 XING | ROAD |
| CON-Z3-UTI-RD-R5-470 |  | Road Marking | 0.8d | 2017-03-06 | 2017-03-07 | CON-Z3-UTI-RD-R5-460 | 144.2d | 0d | Common Labor / Helper [104 h] | 649.06 | 1.3.3.70 | CONS | CONS | ZONE-3 | ROAD-5 | ROAD | ROAD-5 XING | ROAD |
| CON-Z3-UTI-RD-R5-480 |  | Road Opening for Traffic | 0.8d | 2017-03-07 | 2017-03-07 | CON-Z3-UTI-RD-R5-470 | 144.2d | 0d | Common Labor / Helper [52 h] | 432.71 | 1.3.3.70 | CONS | CONS | ZONE-3 | ROAD-5 | ROAD | ROAD-5 XING | ROAD |

Notes:
- CON-Z3-UTI-RD-R5-210: Expenses: (New Expense Item) 1081.77
- CON-Z3-UTI-RD-R5-220: Expenses: (New Expense Item) 4327.08
- CON-Z3-UTI-RD-R5-230: Expenses: (New Expense Item) 1081.77
- CON-Z3-UTI-RD-R5-240: Expenses: (New Expense Item) 1081.77
- CON-Z3-UTI-RD-R5-250: Expenses: (New Expense Item) 1081.77
- CON-Z3-UTI-RD-R5-260: Expenses: (New Expense Item) 1081.77
- CON-Z3-UTI-RD-R5-270: Expenses: (New Expense Item) 1081.77
- CON-Z3-UTI-RD-R5-280: Expenses: (New Expense Item) 1081.77
- CON-Z3-UTI-RD-R5-290: Expenses: (New Expense Item) 2163.54
- CON-Z3-UTI-RD-R5-300: Expenses: (New Expense Item) 1081.77
- CON-Z3-UTI-RD-R5-310: Expenses: (New Expense Item) 3245.31
- CON-Z3-UTI-RD-R5-320: Expenses: (New Expense Item) 2163.54
- CON-Z3-UTI-RD-R5-330: Expenses: (New Expense Item) 649.06
- CON-Z3-UTI-RD-R5-340: Expenses: (New Expense Item) 432.71
- CON-Z3-UTI-RD-R5-350: Expenses: (New Expense Item) 1081.77
- CON-Z3-UTI-RD-R5-360: Expenses: (New Expense Item) 4327.08
- CON-Z3-UTI-RD-R5-370: Expenses: (New Expense Item) 1081.77
- CON-Z3-UTI-RD-R5-380: Expenses: (New Expense Item) 1081.77
- CON-Z3-UTI-RD-R5-390: Expenses: (New Expense Item) 1081.77
- CON-Z3-UTI-RD-R5-400: Expenses: (New Expense Item) 1081.77
- CON-Z3-UTI-RD-R5-410: Expenses: (New Expense Item) 1081.77
- CON-Z3-UTI-RD-R5-420: Expenses: (New Expense Item) 1081.77
- CON-Z3-UTI-RD-R5-430: Expenses: (New Expense Item) 2163.54
- CON-Z3-UTI-RD-R5-440: Expenses: (New Expense Item) 1081.77
- CON-Z3-UTI-RD-R5-450: Expenses: (New Expense Item) 3245.31
- CON-Z3-UTI-RD-R5-460: Expenses: (New Expense Item) 2163.54
- CON-Z3-UTI-RD-R5-470: Expenses: (New Expense Item) 649.06
- CON-Z3-UTI-RD-R5-480: Expenses: (New Expense Item) 432.71

| ID | WBS | Activity | Duration | Start | Finish | Predecessors | Total float | Free float | Resources | Cost | RPI_P2 - BOQ ITEMS | RPI_P2 - CONSTRUCTION | RPI_P2 - PHASE | RPI_P2 - ZONES | RPI_P2 - AREAS | RPI_P2 - DISCIPLINE / WORK TYPE | RPI_P2 - CROSSINGS | RPI_P2 - UTILITY NETWORK |
| --- | --- | --- | --- | --- | --- | --- | --- | --- | --- | --- | --- | --- | --- | --- | --- | --- | --- | --- |
|  | 4 | **Part -2 of 2nd Side of Road** |  | 2017-03-08 | 2017-04-19 |  |  |  |  |  |  |  |  |  |  |  |  |  |
| CON-Z3-UTI-RD-R5-490 |  | Removal of Asphalt | 4d | 2017-03-08 | 2017-03-12 | CON-Z3-UTI-RD-R5-480 | 144.2d | 0d | Common Labor / Helper [26 h]; Operator - Excavator [26 h] | 1,081.77 | 1.3.3.70 | CONS | CONS | ZONE-3 | ROAD-5 | ROAD | ROAD-5 XING | ROAD |
| CON-Z3-UTI-RD-R5-500 |  | Hand Excavation | 8d | 2017-03-13 | 2017-03-21 | CON-Z3-UTI-RD-R5-490 | 144.2d | 0d | Common Labor / Helper [156 h] | 4,327.08 | 1.3.3.70 | CONS | CONS | ZONE-3 | ROAD-5 | ROAD | ROAD-5 XING | ROAD |
| CON-Z3-UTI-RD-R5-510 |  | Installation of Sleeves for Potable Water Lines | 2.4d | 2017-03-22 | 2017-03-25 | CON-Z3-UTI-RD-R5-500 | 144.2d | 0d | Plumber [52 h]; Welder [26 h]; Common Labor / Helper [52 h]; RTR Pipe Crew [26 h]; Operator - Forklift [26 h]; Operator - Mobile Crane [26 h]; Forklift [28 h]; Mobile Crane ( 25-60 Ton) [28 h] | 1,081.77 | 1.3.3.70 | CONS | CONS | ZONE-3 | ROAD-5 | ROAD | ROAD-5 XING | ROAD |
| CON-Z3-UTI-RD-R5-520 |  | Installation of Sleeves for Sea Water Lines | 2.4d | 2017-03-25 | 2017-03-27 | CON-Z3-UTI-RD-R5-510 | 144.2d | 0d | Plumber [52 h]; Welder [26 h]; Common Labor / Helper [52 h]; RTR Pipe Crew [26 h]; Operator - Forklift [26 h]; Operator - Mobile Crane [26 h]; Forklift [28 h]; Mobile Crane ( 25-60 Ton) [28 h] | 1,081.77 | 1.3.3.70 | CONS | CONS | ZONE-3 | ROAD-5 | ROAD | ROAD-5 XING | ROAD |
| CON-Z3-UTI-RD-R5-530 |  | Instalaltion of Sleeves for Sewer Force Mains | 2.4d | 2017-03-27 | 2017-03-30 | CON-Z3-UTI-RD-R5-520 | 144.2d | 0d | Plumber [52 h]; Common Labor / Helper [78 h]; Operator - Mobile Crane [26 h]; Mobile Crane ( 25-60 Ton) [28 h] | 1,081.77 | 1.3.3.70 | CONS | CONS | ZONE-3 | ROAD-5 | ROAD | ROAD-5 XING | ROAD |
| CON-Z3-UTI-RD-R5-540 |  | Instalaltion of Sleeves for Electrical Cables | 2.4d | 2017-03-30 | 2017-04-02 | CON-Z3-UTI-RD-R5-530 | 144.2d | 0d | Plumber [52 h]; Common Labor / Helper [78 h]; Operator - Mobile Crane [26 h]; Mobile Crane ( 25-60 Ton) [28 h] | 1,081.77 | 1.3.3.70 | CONS | CONS | ZONE-3 | ROAD-5 | ROAD | ROAD-5 XING | ROAD |
| CON-Z3-UTI-RD-R5-550 |  | Sandfilling | 1.6d | 2017-04-02 | 2017-04-04 | CON-Z3-UTI-RD-R5-540 | 144.2d | 0d | Common Labor / Helper [78 h]; Operator - Bobcat [26 h]; Driver - Water Tanker [26 h]; Operator - JCB [26 h]; Bobcat [28 h]; Water Tanker [28 h]; JCB [28 h] | 1,081.77 | 1.3.3.70 | CONS | CONS | ZONE-3 | ROAD-5 | ROAD | ROAD-5 XING | ROAD |
| CON-Z3-UTI-RD-R5-560 |  | Final Backfilling | 4d | 2017-04-04 | 2017-04-09 | CON-Z3-UTI-RD-R5-550 | 144.2d | 0d | Common Labor / Helper [104 h]; Road Works Crew [78 h]; Operator - Loader [26 h]; Driver - Dump Truck [26 h]; Operator - Roller (25 Ton) [26 h]; Driver - Fuel Tanker [26 h]; Loader [28 h]; Dump Truck [28 h]; Bobcat [28 h]; Roller-Compactor (2~10 Ton) [28 h]; Roller-Compactor (25 Ton) [28 h]; Water Tanker [28 h] | 1,081.77 | 1.3.3.70 | CONS | CONS | ZONE-3 | ROAD-5 | ROAD | ROAD-5 XING | ROAD |
| CON-Z3-UTI-RD-R5-570 |  | Sub Base Course | 4d | 2017-04-09 | 2017-04-13 | CON-Z3-UTI-RD-R5-560 | 144.2d | 0d | Common Labor / Helper [52 h]; Road Works Crew [52 h]; Operator - Loader [26 h]; Driver - Dump Truck [26 h]; Operator - Grader [26 h]; Driver - Water Tanker [26 h] | 2,163.54 | 1.3.3.70 | CONS | CONS | ZONE-3 | ROAD-5 | ROAD | ROAD-5 XING | ROAD |
| CON-Z3-UTI-RD-R5-580 |  | Base Course | 2.4d | 2017-04-13 | 2017-04-16 | CON-Z3-UTI-RD-R5-570 | 144.2d | 0d | Common Labor / Helper [52 h]; Road Works Crew [52 h]; Operator - Loader [26 h]; Driver - Dump Truck [26 h]; Operator - Grader [26 h]; Driver - Water Tanker [26 h] | 1,081.77 | 1.3.3.70 | CONS | CONS | ZONE-3 | ROAD-5 | ROAD | ROAD-5 XING | ROAD |
| CON-Z3-UTI-RD-R5-590 |  | Asphalt Work | 0.8d | 2017-04-16 | 2017-04-17 | CON-Z3-UTI-RD-R5-580 | 144.2d | 0d | Common Labor / Helper [52 h]; Road Works Crew [52 h]; Operator - Asphalt Paver [26 h]; Operator - Asphalt Compactor / Roller [26 h]; Operator - Roller (25 Ton) [26 h] | 3,245.31 | 1.3.3.70 | CONS | CONS | ZONE-3 | ROAD-5 | ROAD | ROAD-5 XING | ROAD |
| CON-Z3-UTI-RD-R5-600 |  | Wearing Course | 0.8d | 2017-04-17 | 2017-04-18 | CON-Z3-UTI-RD-R5-590 | 144.2d | 0d | Common Labor / Helper [52 h]; Road Works Crew [52 h]; Operator - Asphalt Paver [26 h]; Operator - Asphalt Compactor / Roller [26 h] | 2,163.54 | 1.3.3.70 | CONS | CONS | ZONE-3 | ROAD-5 | ROAD | ROAD-5 XING | ROAD |
| CON-Z3-UTI-RD-R5-610 |  | Road Marking | 0.8d | 2017-04-18 | 2017-04-18 | CON-Z3-UTI-RD-R5-600 | 144.2d | 0d | Common Labor / Helper [104 h] | 649.06 | 1.3.3.70 | CONS | CONS | ZONE-3 | ROAD-5 | ROAD | ROAD-5 XING | ROAD |
| CON-Z3-UTI-RD-R5-620 |  | Road Opening for Traffic | 0.8d | 2017-04-19 | 2017-04-19 | CON-Z3-UTI-RD-R5-610 | 144.2d | 87d | Common Labor / Helper [52 h] | 432.71 | 1.3.3.70 | CONS | CONS | ZONE-3 | ROAD-5 | ROAD | ROAD-5 XING | ROAD |
|  | 5 | **Road 1 Crossing** |  | 2016-11-16 | 2017-04-23 |  |  |  |  |  |  |  |  |  |  |  |  |  |
|  | 1 | **Part -1 of One Side of Road** |  | 2016-11-16 | 2017-01-17 |  |  |  |  |  |  |  |  |  |  |  |  |  |
| CON-Z3-UTI-RD-R1-010 |  | Security / Work Permits & Other Requirements | 12d | 2016-11-16 | 2016-11-30 | CON-Z3-UTI-RD-R5-010 FS+9.6d | 134.8d | 0d | Common Labor / Helper [78 h] | 432.71 | 1.3.3.70 | CONS | CONS | ZONE-3 | ROAD-1 | ROAD | ROAD-1 XING | ROAD |
| CON-Z3-UTI-RD-R1-020 |  | Safety Arrangements and Traffic Diversion | 1.6d | 2016-12-12 | 2016-12-13 | CON-Z3-UTI-RD-R1-010 FS+9.6d | 134.8d | 0d | Common Labor / Helper [78 h] | 649.06 | 1.3.3.70 | CONS | CONS | ZONE-3 | ROAD-1 | ROAD | ROAD-1 XING | ROAD |
| CON-Z3-UTI-RD-R1-030 |  | Relocation of Jersy Barriers | 1.6d | 2016-12-14 | 2016-12-15 | CON-Z3-UTI-RD-R1-020 | 134.8d | 0d | Common Labor / Helper [78 h]; Operator - Mobile Crane [26 h]; Mobile Crane ( 25-60 Ton) [28 h] | 649.06 | 1.3.3.70 | CONS | CONS | ZONE-3 | ROAD-1 | ROAD | ROAD-1 XING | ROAD |
| CON-Z3-UTI-RD-R1-040 |  | Removal of Asphalt | 1.6d | 2016-12-15 | 2016-12-18 | CON-Z3-UTI-RD-R1-030 | 134.8d | 0d | Common Labor / Helper [26 h]; Operator - Excavator [26 h] | 1,081.77 | 1.3.3.70 | CONS | CONS | ZONE-3 | ROAD-1 | ROAD | ROAD-1 XING | ROAD |
| CON-Z3-UTI-RD-R1-050 |  | Hand Excavation | 4.8d | 2016-12-18 | 2016-12-22 | CON-Z3-UTI-RD-R1-040 | 134.8d | 0d | Common Labor / Helper [156 h] | 3,245.31 | 1.3.3.70 | CONS | CONS | ZONE-3 | ROAD-1 | ROAD | ROAD-1 XING | ROAD |
| CON-Z3-UTI-RD-R1-060 |  | Installation of Sleeves for Utilities Crossing Road 1 | 6.4d | 2016-12-24 | 2016-12-31 | CON-Z3-UTI-RD-R1-050 | 134.8d | 0d | Plumber [26 h]; Common Labor / Helper [52 h]; RTR Pipe Crew [26 h] | 3,245.31 | 1.3.3.70 | CONS | CONS | ZONE-3 | ROAD-1 | ROAD | ROAD-1 XING | ROAD |
| CON-Z3-UTI-RD-R1-070 |  | Sandfilling | 1.6d | 2016-12-31 | 2017-01-01 | CON-Z3-UTI-RD-R1-060 | 134.8d | 0d | Common Labor / Helper [78 h]; Operator - Bobcat [26 h]; Driver - Water Tanker [26 h]; Operator - JCB [26 h]; Bobcat [28 h]; Water Tanker [28 h]; JCB [28 h] | 1,081.77 | 1.3.3.70 | CONS | CONS | ZONE-3 | ROAD-1 | ROAD | ROAD-1 XING | ROAD |
| CON-Z3-UTI-RD-R1-080 |  | Final Backfilling | 4d | 2017-01-02 | 2017-01-05 | CON-Z3-UTI-RD-R1-070 | 134.8d | 0d | Common Labor / Helper [104 h]; Road Works Crew [78 h]; Operator - Loader [26 h]; Driver - Dump Truck [26 h]; Operator - Roller (25 Ton) [26 h]; Driver - Fuel Tanker [26 h]; Loader [28 h]; Dump Truck [28 h]; Bobcat [28 h]; Roller-Compactor (2~10 Ton) [28 h]; Roller-Compactor (25 Ton) [28 h]; Water Tanker [28 h] | 2,163.54 | 1.3.3.70 | CONS | CONS | ZONE-3 | ROAD-1 | ROAD | ROAD-1 XING | ROAD |
| CON-Z3-UTI-RD-R1-090 |  | Sub Base Course | 4d | 2017-01-07 | 2017-01-10 | CON-Z3-UTI-RD-R1-080 | 134.8d | 0d | Common Labor / Helper [52 h]; Road Works Crew [52 h]; Operator - Loader [26 h]; Driver - Dump Truck [26 h]; Operator - Grader [26 h]; Driver - Water Tanker [26 h] | 2,596.25 | 1.3.3.70 | CONS | CONS | ZONE-3 | ROAD-1 | ROAD | ROAD-1 XING | ROAD |
| CON-Z3-UTI-RD-R1-100 |  | Base Course | 2.4d | 2017-01-11 | 2017-01-14 | CON-Z3-UTI-RD-R1-090 | 134.8d | 0d | Common Labor / Helper [52 h]; Road Works Crew [52 h]; Operator - Loader [26 h]; Driver - Dump Truck [26 h]; Operator - Grader [26 h]; Driver - Water Tanker [26 h] | 2,163.54 | 1.3.3.70 | CONS | CONS | ZONE-3 | ROAD-1 | ROAD | ROAD-1 XING | ROAD |
| CON-Z3-UTI-RD-R1-110 |  | Asphalt Work | 0.8d | 2017-01-14 | 2017-01-15 | CON-Z3-UTI-RD-R1-100 | 134.8d | 0d | Common Labor / Helper [52 h]; Road Works Crew [52 h]; Operator - Asphalt Paver [26 h]; Operator - Asphalt Compactor / Roller [26 h]; Operator - Roller (25 Ton) [26 h] | 2,163.54 | 1.3.3.70 | CONS | CONS | ZONE-3 | ROAD-1 | ROAD | ROAD-1 XING | ROAD |
| CON-Z3-UTI-RD-R1-120 |  | Wearing Course | 0.8d | 2017-01-15 | 2017-01-15 | CON-Z3-UTI-RD-R1-110 | 134.8d | 0d | Common Labor / Helper [52 h]; Road Works Crew [52 h]; Operator - Asphalt Paver [26 h]; Operator - Asphalt Compactor / Roller [26 h] | 1,081.77 | 1.3.3.70 | CONS | CONS | ZONE-3 | ROAD-1 | ROAD | ROAD-1 XING | ROAD |
| CON-Z3-UTI-RD-R1-130 |  | Road Marking | 0.8d | 2017-01-16 | 2017-01-16 | CON-Z3-UTI-RD-R1-120 | 134.8d | 0d | Common Labor / Helper [104 h] | 649.06 | 1.3.3.70 | CONS | CONS | ZONE-3 | ROAD-1 | ROAD | ROAD-1 XING | ROAD |
| CON-Z3-UTI-RD-R1-140 |  | Road Opening for Traffic | 0.8d | 2017-01-16 | 2017-01-17 | CON-Z3-UTI-RD-R1-130 | 134.8d | 0d | Common Labor / Helper [52 h] | 432.71 | 1.3.3.70 | CONS | CONS | ZONE-3 | ROAD-1 | ROAD | ROAD-1 XING | ROAD |

Notes:
- CON-Z3-UTI-RD-R5-490: Expenses: (New Expense Item) 1081.77
- CON-Z3-UTI-RD-R5-500: Expenses: (New Expense Item) 4327.08
- CON-Z3-UTI-RD-R5-510: Expenses: (New Expense Item) 1081.77
- CON-Z3-UTI-RD-R5-520: Expenses: (New Expense Item) 1081.77
- CON-Z3-UTI-RD-R5-530: Expenses: (New Expense Item) 1081.77
- CON-Z3-UTI-RD-R5-540: Expenses: (New Expense Item) 1081.77
- CON-Z3-UTI-RD-R5-550: Expenses: (New Expense Item) 1081.77
- CON-Z3-UTI-RD-R5-560: Expenses: (New Expense Item) 1081.77
- CON-Z3-UTI-RD-R5-570: Expenses: (New Expense Item) 2163.54
- CON-Z3-UTI-RD-R5-580: Expenses: (New Expense Item) 1081.77
- CON-Z3-UTI-RD-R5-590: Expenses: (New Expense Item) 3245.31
- CON-Z3-UTI-RD-R5-600: Expenses: (New Expense Item) 2163.54
- CON-Z3-UTI-RD-R5-610: Expenses: (New Expense Item) 649.06
- CON-Z3-UTI-RD-R5-620: Expenses: (New Expense Item) 432.71
- CON-Z3-UTI-RD-R1-010: Expenses: (New Expense Item) 432.71
- CON-Z3-UTI-RD-R1-020: Expenses: (New Expense Item) 649.06
- CON-Z3-UTI-RD-R1-030: Expenses: (New Expense Item) 649.06
- CON-Z3-UTI-RD-R1-040: Expenses: (New Expense Item) 1081.77
- CON-Z3-UTI-RD-R1-050: Expenses: (New Expense Item) 3245.31
- CON-Z3-UTI-RD-R1-060: Expenses: (New Expense Item) 3245.31
- CON-Z3-UTI-RD-R1-070: Expenses: (New Expense Item) 1081.77
- CON-Z3-UTI-RD-R1-080: Expenses: (New Expense Item) 2163.54
- CON-Z3-UTI-RD-R1-090: Expenses: (New Expense Item) 2596.25
- CON-Z3-UTI-RD-R1-100: Expenses: (New Expense Item) 2163.54
- CON-Z3-UTI-RD-R1-110: Expenses: (New Expense Item) 2163.54
- CON-Z3-UTI-RD-R1-120: Expenses: (New Expense Item) 1081.77
- CON-Z3-UTI-RD-R1-130: Expenses: (New Expense Item) 649.06
- CON-Z3-UTI-RD-R1-140: Expenses: (New Expense Item) 432.71

| ID | WBS | Activity | Duration | Start | Finish | Predecessors | Total float | Free float | Resources | Cost | RPI_P2 - BOQ ITEMS | RPI_P2 - CONSTRUCTION | RPI_P2 - PHASE | RPI_P2 - ZONES | RPI_P2 - AREAS | RPI_P2 - DISCIPLINE / WORK TYPE | RPI_P2 - CROSSINGS | RPI_P2 - UTILITY NETWORK |
| --- | --- | --- | --- | --- | --- | --- | --- | --- | --- | --- | --- | --- | --- | --- | --- | --- | --- | --- |
|  | 2 | **Part -2 of One Side of Road** |  | 2017-01-17 | 2017-02-18 |  |  |  |  |  |  |  |  |  |  |  |  |  |
| CON-Z3-UTI-RD-R1-150 |  | Removal of Asphalt | 1.6d | 2017-01-17 | 2017-01-19 | CON-Z3-UTI-RD-R1-140 | 134.8d | 0d | Common Labor / Helper [26 h]; Operator - Excavator [26 h] | 1,081.77 | 1.3.3.70 | CONS | CONS | ZONE-3 | ROAD-1 | ROAD | ROAD-1 XING | ROAD |
| CON-Z3-UTI-RD-R1-160 |  | Hand Excavation | 4.8d | 2017-01-19 | 2017-01-24 | CON-Z3-UTI-RD-R1-150 | 134.8d | 0d | Common Labor / Helper [156 h] | 3,245.31 | 1.3.3.70 | CONS | CONS | ZONE-3 | ROAD-1 | ROAD | ROAD-1 XING | ROAD |
| CON-Z3-UTI-RD-R1-170 |  | Installation of Sleeves for Utilities Crossing Road 1 | 6.4d | 2017-01-25 | 2017-02-01 | CON-Z3-UTI-RD-R1-160 | 134.8d | 0d | Plumber [26 h]; Common Labor / Helper [52 h]; RTR Pipe Crew [26 h] | 3,245.31 | 1.3.3.70 | CONS | CONS | ZONE-3 | ROAD-1 | ROAD | ROAD-1 XING | ROAD |
| CON-Z3-UTI-RD-R1-180 |  | Sandfilling | 1.6d | 2017-02-01 | 2017-02-02 | CON-Z3-UTI-RD-R1-170 | 134.8d | 0d | Common Labor / Helper [78 h]; Operator - Bobcat [26 h]; Driver - Water Tanker [26 h]; Operator - JCB [26 h]; Bobcat [28 h]; Water Tanker [28 h]; JCB [28 h] | 1,081.77 | 1.3.3.70 | CONS | CONS | ZONE-3 | ROAD-1 | ROAD | ROAD-1 XING | ROAD |
| CON-Z3-UTI-RD-R1-190 |  | Final Backfilling | 4d | 2017-02-04 | 2017-02-07 | CON-Z3-UTI-RD-R1-180 | 134.8d | 0d | Common Labor / Helper [104 h]; Road Works Crew [78 h]; Operator - Loader [26 h]; Driver - Dump Truck [26 h]; Operator - Roller (25 Ton) [26 h]; Driver - Fuel Tanker [26 h]; Loader [28 h]; Dump Truck [28 h]; Bobcat [28 h]; Roller-Compactor (2~10 Ton) [28 h]; Roller-Compactor (25 Ton) [28 h]; Water Tanker [28 h] | 2,163.54 | 1.3.3.70 | CONS | CONS | ZONE-3 | ROAD-1 | ROAD | ROAD-1 XING | ROAD |
| CON-Z3-UTI-RD-R1-200 |  | Sub Base Course | 4d | 2017-02-08 | 2017-02-12 | CON-Z3-UTI-RD-R1-190 | 134.8d | 0d | Common Labor / Helper [52 h]; Road Works Crew [52 h]; Operator - Loader [26 h]; Driver - Dump Truck [26 h]; Operator - Grader [26 h]; Driver - Water Tanker [26 h] | 3,245.31 | 1.3.3.70 | CONS | CONS | ZONE-3 | ROAD-1 | ROAD | ROAD-1 XING | ROAD |
| CON-Z3-UTI-RD-R1-210 |  | Base Course | 2.4d | 2017-02-13 | 2017-02-15 | CON-Z3-UTI-RD-R1-200 | 134.8d | 0d | Common Labor / Helper [52 h]; Road Works Crew [52 h]; Operator - Loader [26 h]; Driver - Dump Truck [26 h]; Operator - Grader [26 h]; Driver - Water Tanker [26 h] | 2,163.54 | 1.3.3.70 | CONS | CONS | ZONE-3 | ROAD-1 | ROAD | ROAD-1 XING | ROAD |
| CON-Z3-UTI-RD-R1-220 |  | Asphalt Work | 0.8d | 2017-02-15 | 2017-02-16 | CON-Z3-UTI-RD-R1-210 | 134.8d | 0d | Common Labor / Helper [52 h]; Road Works Crew [52 h]; Operator - Asphalt Paver [26 h]; Operator - Asphalt Compactor / Roller [26 h]; Operator - Roller (25 Ton) [26 h] | 3,245.31 | 1.3.3.70 | CONS | CONS | ZONE-3 | ROAD-1 | ROAD | ROAD-1 XING | ROAD |
| CON-Z3-UTI-RD-R1-230 |  | Wearing Course | 0.8d | 2017-02-16 | 2017-02-16 | CON-Z3-UTI-RD-R1-220 | 134.8d | 0d | Common Labor / Helper [52 h]; Road Works Crew [52 h]; Operator - Asphalt Paver [26 h]; Operator - Asphalt Compactor / Roller [26 h] | 1,081.77 | 1.3.3.70 | CONS | CONS | ZONE-3 | ROAD-1 | ROAD | ROAD-1 XING | ROAD |
| CON-Z3-UTI-RD-R1-240 |  | Road Marking | 0.8d | 2017-02-18 | 2017-02-18 | CON-Z3-UTI-RD-R1-230 | 134.8d | 0d | Common Labor / Helper [104 h] | 649.06 | 1.3.3.70 | CONS | CONS | ZONE-3 | ROAD-1 | ROAD | ROAD-1 XING | ROAD |
| CON-Z3-UTI-RD-R1-250 |  | Road Opening for Traffic | 0.8d | 2017-02-18 | 2017-02-18 | CON-Z3-UTI-RD-R1-240 SS | 134.8d | 0d | Common Labor / Helper [52 h] | 432.71 | 1.3.3.70 | CONS | CONS | ZONE-3 | ROAD-1 | ROAD | ROAD-1 XING | ROAD |
|  | 3 | **Part -1 of 2nd Side of Road** |  | 2017-02-18 | 2017-03-21 |  |  |  |  |  |  |  |  |  |  |  |  |  |
| CON-Z3-UTI-RD-R1-260 |  | Removal of Asphalt | 1.6d | 2017-02-18 | 2017-02-20 | CON-Z3-UTI-RD-R1-250 | 134.8d | 0d | Common Labor / Helper [26 h]; Operator - Excavator [26 h] | 1,081.77 | 1.3.3.70 | CONS | CONS | ZONE-3 | ROAD-1 | ROAD | ROAD-1 XING | ROAD |
| CON-Z3-UTI-RD-R1-270 |  | Hand Excavation | 4.8d | 2017-02-20 | 2017-02-26 | CON-Z3-UTI-RD-R1-260 | 134.8d | 0d | Common Labor / Helper [156 h] | 3,245.31 | 1.3.3.70 | CONS | CONS | ZONE-3 | ROAD-1 | ROAD | ROAD-1 XING | ROAD |
| CON-Z3-UTI-RD-R1-280 |  | Installation of Sleeves for Utilities Crossing Road 1 | 6.4d | 2017-02-26 | 2017-03-05 | CON-Z3-UTI-RD-R1-270 | 134.8d | 0d | Plumber [26 h]; Common Labor / Helper [52 h]; RTR Pipe Crew [26 h] | 3,245.31 | 1.3.3.70 | CONS | CONS | ZONE-3 | ROAD-1 | ROAD | ROAD-1 XING | ROAD |
| CON-Z3-UTI-RD-R1-290 |  | Sandfilling | 1.6d | 2017-03-05 | 2017-03-07 | CON-Z3-UTI-RD-R1-280 | 134.8d | 0d | Common Labor / Helper [78 h]; Operator - Bobcat [26 h]; Driver - Water Tanker [26 h]; Operator - JCB [26 h]; Bobcat [28 h]; Water Tanker [28 h]; JCB [28 h] | 1,081.77 | 1.3.3.70 | CONS | CONS | ZONE-3 | ROAD-1 | ROAD | ROAD-1 XING | ROAD |
| CON-Z3-UTI-RD-R1-300 |  | Final Backfilling | 4d | 2017-03-07 | 2017-03-12 | CON-Z3-UTI-RD-R1-290 | 134.8d | 0d | Common Labor / Helper [104 h]; Road Works Crew [78 h]; Operator - Loader [26 h]; Driver - Dump Truck [26 h]; Operator - Roller (25 Ton) [26 h]; Driver - Fuel Tanker [26 h]; Loader [28 h]; Dump Truck [28 h]; Bobcat [28 h]; Roller-Compactor (2~10 Ton) [28 h]; Roller-Compactor (25 Ton) [28 h]; Water Tanker [28 h] | 2,163.54 | 1.3.3.70 | CONS | CONS | ZONE-3 | ROAD-1 | ROAD | ROAD-1 XING | ROAD |
| CON-Z3-UTI-RD-R1-310 |  | Sub Base Course | 4d | 2017-03-12 | 2017-03-16 | CON-Z3-UTI-RD-R1-300 | 134.8d | 0d | Common Labor / Helper [52 h]; Road Works Crew [52 h]; Operator - Loader [26 h]; Driver - Dump Truck [26 h]; Operator - Grader [26 h]; Driver - Water Tanker [26 h] | 3,245.31 | 1.3.3.70 | CONS | CONS | ZONE-3 | ROAD-1 | ROAD | ROAD-1 XING | ROAD |
| CON-Z3-UTI-RD-R1-320 |  | Base Course | 2.4d | 2017-03-16 | 2017-03-19 | CON-Z3-UTI-RD-R1-310 | 134.8d | 0d | Common Labor / Helper [52 h]; Road Works Crew [52 h]; Operator - Loader [26 h]; Driver - Dump Truck [26 h]; Operator - Grader [26 h]; Driver - Water Tanker [26 h] | 2,163.54 | 1.3.3.70 | CONS | CONS | ZONE-3 | ROAD-1 | ROAD | ROAD-1 XING | ROAD |
| CON-Z3-UTI-RD-R1-330 |  | Asphalt Work | 0.8d | 2017-03-19 | 2017-03-20 | CON-Z3-UTI-RD-R1-320 | 134.8d | 0d | Common Labor / Helper [52 h]; Road Works Crew [52 h]; Operator - Asphalt Paver [26 h]; Operator - Asphalt Compactor / Roller [26 h]; Operator - Roller (25 Ton) [26 h] | 3,245.31 | 1.3.3.70 | CONS | CONS | ZONE-3 | ROAD-1 | ROAD | ROAD-1 XING | ROAD |
| CON-Z3-UTI-RD-R1-340 |  | Wearing Course | 0.8d | 2017-03-20 | 2017-03-21 | CON-Z3-UTI-RD-R1-330 | 134.8d | 0d | Common Labor / Helper [52 h]; Road Works Crew [52 h]; Operator - Asphalt Paver [26 h]; Operator - Asphalt Compactor / Roller [26 h] | 1,081.77 | 1.3.3.70 | CONS | CONS | ZONE-3 | ROAD-1 | ROAD | ROAD-1 XING | ROAD |
| CON-Z3-UTI-RD-R1-350 |  | Road Marking | 0.8d | 2017-03-20 | 2017-03-21 | CON-Z3-UTI-RD-R1-340 SS | 134.8d | 0d | Common Labor / Helper [104 h] | 649.06 | 1.3.3.70 | CONS | CONS | ZONE-3 | ROAD-1 | ROAD | ROAD-1 XING | ROAD |
| CON-Z3-UTI-RD-R1-360 |  | Road Opening for Traffic | 0.8d | 2017-03-21 | 2017-03-21 | CON-Z3-UTI-RD-R1-350 | 134.8d | 0d | Common Labor / Helper [52 h] | 432.71 | 1.3.3.70 | CONS | CONS | ZONE-3 | ROAD-1 | ROAD | ROAD-1 XING | ROAD |

Notes:
- CON-Z3-UTI-RD-R1-150: Expenses: (New Expense Item) 1081.77
- CON-Z3-UTI-RD-R1-160: Expenses: (New Expense Item) 3245.31
- CON-Z3-UTI-RD-R1-170: Expenses: (New Expense Item) 3245.31
- CON-Z3-UTI-RD-R1-180: Expenses: (New Expense Item) 1081.77
- CON-Z3-UTI-RD-R1-190: Expenses: (New Expense Item) 2163.54
- CON-Z3-UTI-RD-R1-200: Expenses: (New Expense Item) 3245.31
- CON-Z3-UTI-RD-R1-210: Expenses: (New Expense Item) 2163.54
- CON-Z3-UTI-RD-R1-220: Expenses: (New Expense Item) 3245.31
- CON-Z3-UTI-RD-R1-230: Expenses: (New Expense Item) 1081.77
- CON-Z3-UTI-RD-R1-240: Expenses: (New Expense Item) 649.06
- CON-Z3-UTI-RD-R1-250: Expenses: (New Expense Item) 432.71
- CON-Z3-UTI-RD-R1-260: Expenses: (New Expense Item) 1081.77
- CON-Z3-UTI-RD-R1-270: Expenses: (New Expense Item) 3245.31
- CON-Z3-UTI-RD-R1-280: Expenses: (New Expense Item) 3245.31
- CON-Z3-UTI-RD-R1-290: Expenses: (New Expense Item) 1081.77
- CON-Z3-UTI-RD-R1-300: Expenses: (New Expense Item) 2163.54
- CON-Z3-UTI-RD-R1-310: Expenses: (New Expense Item) 3245.31
- CON-Z3-UTI-RD-R1-320: Expenses: (New Expense Item) 2163.54
- CON-Z3-UTI-RD-R1-330: Expenses: (New Expense Item) 3245.31
- CON-Z3-UTI-RD-R1-340: Expenses: (New Expense Item) 1081.77
- CON-Z3-UTI-RD-R1-350: Expenses: (New Expense Item) 649.06
- CON-Z3-UTI-RD-R1-360: Expenses: (New Expense Item) 432.71

| ID | WBS | Activity | Duration | Start | Finish | Predecessors | Total float | Free float | Resources | Cost | RPI_P2 - BOQ ITEMS | RPI_P2 - CONSTRUCTION | RPI_P2 - PHASE | RPI_P2 - ZONES | RPI_P2 - AREAS | RPI_P2 - DISCIPLINE / WORK TYPE | RPI_P2 - CROSSINGS | RPI_P2 - UTILITY NETWORK |
| --- | --- | --- | --- | --- | --- | --- | --- | --- | --- | --- | --- | --- | --- | --- | --- | --- | --- | --- |
|  | 4 | **Part -2 of 2nd Side of Road** |  | 2017-03-22 | 2017-04-23 |  |  |  |  |  |  |  |  |  |  |  |  |  |
| CON-Z3-UTI-RD-R1-370 |  | Removal of Asphalt | 1.6d | 2017-03-22 | 2017-03-23 | CON-Z3-UTI-RD-R1-360 | 134.8d | 0d | Common Labor / Helper [26 h]; Operator - Excavator [26 h] | 1,081.77 | 1.3.3.70 | CONS | CONS | ZONE-3 | ROAD-1 | ROAD | ROAD-1 XING | ROAD |
| CON-Z3-UTI-RD-R1-380 |  | Hand Excavation | 4.8d | 2017-03-23 | 2017-03-29 | CON-Z3-UTI-RD-R1-370 | 134.8d | 0d | Common Labor / Helper [156 h] | 3,245.31 | 1.3.3.70 | CONS | CONS | ZONE-3 | ROAD-1 | ROAD | ROAD-1 XING | ROAD |
| CON-Z3-UTI-RD-R1-390 |  | Installation of Sleeves for Utilities Crossing Road 1 | 6.4d | 2017-03-29 | 2017-04-05 | CON-Z3-UTI-RD-R1-380 | 134.8d | 0d | Plumber [26 h]; Common Labor / Helper [52 h]; RTR Pipe Crew [26 h] | 3,245.31 | 1.3.3.70 | CONS | CONS | ZONE-3 | ROAD-1 | ROAD | ROAD-1 XING | ROAD |
| CON-Z3-UTI-RD-R1-400 |  | Sandfilling | 1.6d | 2017-04-05 | 2017-04-08 | CON-Z3-UTI-RD-R1-390 | 134.8d | 0d | Common Labor / Helper [78 h]; Operator - Bobcat [26 h]; Driver - Water Tanker [26 h]; Operator - JCB [26 h]; Bobcat [28 h]; Water Tanker [28 h]; JCB [28 h] | 1,081.77 | 1.3.3.70 | CONS | CONS | ZONE-3 | ROAD-1 | ROAD | ROAD-1 XING | ROAD |
| CON-Z3-UTI-RD-R1-410 |  | Final Backfilling | 4d | 2017-04-08 | 2017-04-12 | CON-Z3-UTI-RD-R1-400 | 134.8d | 0d | Common Labor / Helper [104 h]; Road Works Crew [78 h]; Operator - Loader [26 h]; Driver - Dump Truck [26 h]; Operator - Roller (25 Ton) [26 h]; Driver - Fuel Tanker [26 h]; Loader [28 h]; Dump Truck [28 h]; Bobcat [28 h]; Roller-Compactor (2~10 Ton) [28 h]; Roller-Compactor (25 Ton) [28 h]; Water Tanker [28 h] | 2,163.54 | 1.3.3.70 | CONS | CONS | ZONE-3 | ROAD-1 | ROAD | ROAD-1 XING | ROAD |
| CON-Z3-UTI-RD-R1-420 |  | Sub Base Course | 4d | 2017-04-12 | 2017-04-17 | CON-Z3-UTI-RD-R1-410 | 134.8d | 0d | Common Labor / Helper [52 h]; Road Works Crew [52 h]; Operator - Loader [26 h]; Driver - Dump Truck [26 h]; Operator - Grader [26 h]; Driver - Water Tanker [26 h] | 3,245.31 | 1.3.3.70 | CONS | CONS | ZONE-3 | ROAD-1 | ROAD | ROAD-1 XING | ROAD |
| CON-Z3-UTI-RD-R1-430 |  | Base Course | 2.4d | 2017-04-17 | 2017-04-19 | CON-Z3-UTI-RD-R1-420 | 134.8d | 0d | Common Labor / Helper [52 h]; Road Works Crew [52 h]; Operator - Loader [26 h]; Driver - Dump Truck [26 h]; Operator - Grader [26 h]; Driver - Water Tanker [26 h] | 2,163.54 | 1.3.3.70 | CONS | CONS | ZONE-3 | ROAD-1 | ROAD | ROAD-1 XING | ROAD |
| CON-Z3-UTI-RD-R1-440 |  | Asphalt Work | 0.8d | 2017-04-19 | 2017-04-20 | CON-Z3-UTI-RD-R1-430 | 134.8d | 0d | Common Labor / Helper [52 h]; Road Works Crew [52 h]; Operator - Asphalt Paver [26 h]; Operator - Asphalt Compactor / Roller [26 h]; Operator - Roller (25 Ton) [26 h] | 3,245.31 | 1.3.3.70 | CONS | CONS | ZONE-3 | ROAD-1 | ROAD | ROAD-1 XING | ROAD |
| CON-Z3-UTI-RD-R1-450 |  | Wearing Course | 0.8d | 2017-04-20 | 2017-04-22 | CON-Z3-UTI-RD-R1-440 | 134.8d | 0d | Operator - Asphalt Compactor / Roller [26 h]; Common Labor / Helper [52 h]; Road Works Crew [52 h]; Operator - Asphalt Paver [26 h] | 1,081.77 | 1.3.3.70 | CONS | CONS | ZONE-3 | ROAD-1 | ROAD | ROAD-1 XING | ROAD |
| CON-Z3-UTI-RD-R1-460 |  | Road Marking | 0.8d | 2017-04-20 | 2017-04-22 | CON-Z3-UTI-RD-R1-450 SS | 134.8d | 0d | Common Labor / Helper [104 h] | 649.06 | 1.3.3.70 | CONS | CONS | ZONE-3 | ROAD-1 | ROAD | ROAD-1 XING | ROAD |
| CON-Z3-UTI-RD-R1-470 |  | Road Opening for Traffic | 0.8d | 2017-04-22 | 2017-04-23 | CON-Z3-UTI-RD-R1-460 | 134.8d | 84d | Common Labor / Helper [52 h] | 432.71 | 1.3.3.70 | CONS | CONS | ZONE-3 | ROAD-1 | ROAD | ROAD-1 XING | ROAD |
|  | 6 | **Interfaces and Tie in to Exsiting Roads** |  | 2017-07-06 | 2017-08-03 |  |  |  |  |  |  |  |  |  |  |  |  |  |
| CON-Z3-UTI-RD-GE-010 |  | Tie in Connection With Exsiting KAUST Roads | 24d | 2017-07-06 | 2017-08-03 | CON-Z3-UTI-RD-R4-080 FS+3d, CON-Z3-UTI-RD-R1-470 FF | 50.8d | 0.6d | Common Labor / Helper [52 h]; Road Works Crew [52 h] | 19,231.45 | 1.3.3.70 | CONS | CONS | ZONE-3 |  | ROAD |  | ROAD |
|  | 8 | **Electrical Works** |  | 2016-10-12 | 2017-08-30 |  |  |  |  |  |  |  |  |  |  |  |  |  |
|  | 8 | **Testing and Precommissioning of Already Installed MV Cables for Loop 4,6,7,8,9,11** |  | 2016-10-12 | 2016-12-07 |  |  |  |  |  |  |  |  |  |  |  |  |  |
| CON-Z3-UT-ELE-TC-010 |  | Testing and Precommissioning of Already Installed MV Cables for Loop 4,6,7,8,9,11 | 48d | 2016-10-12 | 2016-12-07 | GE-MS-ENG-ENG-0030, CON-CON-CON-CON-0010 FS+50d, GE-MS-ENG-ENG-0020 | 2.8d | 0d | Electrician [16800 h]; Common Labor / Helper [14400 h]; Driver - Water Tanker [1920 h]; Water Tanker [1920 h] | 20,000 | 1.3.3.90 | CONS | CONS | ZONE-3 |  | ELEC |  | POWER |
|  | 1 | **Remaining MV Cables,Transformers,RMU'S and Unit Sub Stations (Loop 4)** |  | 2016-11-05 | 2017-08-23 |  |  |  |  |  |  |  |  |  |  |  |  |  |
| CONC-Z3-UTIL-ELE-010 |  | Excavation and Cleaning for MV cable trench | 12d | 2016-11-05 | 2016-11-19 | CON-Z3-UT-ELE-TC-010 SS+20d | 2.8d | 0d | Common Labor / Helper [624 h]; Operator - JCB [60 h]; JCB [60 h] | 55,566.88 | 1.3.3.90 | CONS | CONS | ZONE-3 |  | ELEC |  | POWER |
| CONC-Z3-UTIL-ELE-020 |  | Sand Bedding of MV Cable Trench | 8d | 2016-11-19 | 2016-11-28 | CONC-Z3-UTIL-ELE-010 | 90.8d | 83d | Common Labor / Helper [416 h]; Operator - Loader [104 h]; Driver - Dump Truck [104 h]; Operator - Bobcat [104 h]; Operator - JCB [160 h]; Loader [112 h]; Dump Truck [112 h]; Bobcat [224 h]; JCB [224 h] | 37,783.44 | 1.3.3.90 | CONS | CONS | ZONE-3 |  | ELEC |  | POWER |
| CONC-Z3-UTIL-ELE-030 |  | MV Cable Pulling | 16d | 2017-03-05 | 2017-03-23 | CONC-Z3-UTIL-ELE-020, PR-Z3-EW-EW-36-0080 | 7.8d | 0d | Electrician [78 h]; Common Labor / Helper [104 h]; Operator - Forklift [26 h]; Forklift [28 h] | 113,350.32 | 1.3.3.90 | CONS | CONS | ZONE-3 |  | ELEC |  | POWER |
| CONC-Z3-UTIL-ELE-040 |  | Splicing and Termination of MV Cables | 8d | 2017-03-23 | 2017-04-02 | PR-Z3-EW-EW-37-0080, CONC-Z3-UTIL-ELE-030 | 7.8d | 0d | Electrician [78 h]; Specialist Works Crew [26 h] | 37,783.44 | 1.3.3.90 | CONS | CONS | ZONE-3 |  | ELEC |  | POWER |
| CONC-Z3-UTIL-ELE-050 |  | Soft Sand Filling | 8d | 2017-04-02 | 2017-04-11 | CONC-Z3-UTIL-ELE-040 | 7.8d | 0d | Common Labor / Helper [104 h]; Driver - Water Tanker [26 h]; Operator - JCB [26 h]; Water Tanker [28 h]; JCB [28 h] | 15,113.38 | 1.3.3.90 | CONS | CONS | ZONE-3 |  | ELEC |  | POWER |
| CONC-Z3-UTIL-ELE-060 |  | Installation of Red Tiles and Warning Tape | 16d | 2017-04-11 | 2017-04-30 | PR-Z3-EW-EW-40-0080, PR-Z3-UT-PW-147-0080, CONC-Z3-UTIL-ELE-050 | 7.8d | 0d | Common Labor / Helper [78 h]; Block Mason [52 h]; Tiling Crew [52 h] | 22,670.06 | 1.3.3.90 | CONS | CONS | ZONE-3 |  | ELEC |  | POWER |
| CONC-Z3-UTIL-ELE-070 |  | Final Backfilling | 24d | 2017-05-04 | 2017-06-01 | CONC-Z3-UTIL-ELE-060 SS+20d | 7.8d | 0d | Common Labor / Helper [104 h]; Operator - Loader [26 h]; Driver - Dump Truck [26 h]; Operator - Bobcat [26 h]; Operator - Asphalt Compactor / Roller [26 h]; Operator - Roller-Compactor (2~10 Ton) [26 h]; Driver - Water Tanker [26 h]; Operator - JCB [26 h]; Loader [28 h]; Dump Truck [28 h]; Bobcat [28 h]; Roller-Compactor (2~10 Ton) [28 h]; Roller-Compactor (25 Ton) [28 h]; Water Tanker [28 h] | 75,566.88 | 1.3.3.90 | CONS | CONS | ZONE-3 |  | ELEC |  | POWER |
| CONC-Z3-UTIL-ELE-790 |  | Instalaltion of Cable Markers | 16d | 2017-06-01 | 2017-06-20 | CONC-Z3-UTIL-ELE-070, PR-Z3-EW-EW-47-0080 | 59.8d | 0d | Shuttering Carpenter [26 h]; Common Labor / Helper [78 h] | 37,783.44 | 1.3.3.90 | CONS | CONS | ZONE-3 |  | ELEC |  | POWER |
| CONC-Z3-UTIL-ELE-080 |  | Testing and Precommissioning of MV Cables | 20d | 2017-06-19 | 2017-07-17 | CONC-Z3-UTIL-ELE-070 FS+15d | 7.8d | 0d | Electrician [78 h]; Common Labor / Helper [26 h] | 75,566.88 | 1.3.3.90 | CONS | CONS | ZONE-3 |  | ELEC |  | POWER |
| CONC-Z3-UTIL-ELE-090 |  | Installation of Concrete Foundation for remaining RMU'S and Tranformers | 16d | 2017-06-24 | 2017-07-17 | PR-Z3-EW-ME-64-0080, CONC-Z3-UTIL-ELE-080 SS+4d, PR-Z4-EW-EL-180-0080 | 7.8d | 0d | Steel Fixer [52 h]; Shuttering Carpenter [78 h]; Concrete Mason [78 h]; Common Labor / Helper [52 h]; Driver - Conc. Transit Mixers [26 h]; Operator - Concrete Pump [26 h]; Concrete Transit Mixers [28 h]; Concrete Pump [28 h] | 37,783.44 | 1.3.3.90 | CONS | CONS | ZONE-3 |  | ELEC |  | POWER |
| CONC-Z3-UTIL-ELE-100 |  | Installation of RMU'S,Transformers and Unit Substations | 16d | 2017-07-17 | 2017-08-05 | CONC-Z3-UTIL-ELE-090 | 7.8d | 0d | Electrician [78 h]; Mechanical Technician [26 h]; HVAC Crew [26 h] | 37,783.44 | 1.3.3.90 | CONS | CONS | ZONE-3 |  | ELEC |  | POWER |
| CONC-Z3-UTIL-ELE-110 |  | Testing and Precommissioning of RMU'S Transformers and Unit Substations | 16d | 2017-07-22 | 2017-08-09 | CONC-Z3-UTIL-ELE-100 SS+4d, CONC-Z3-UTIL-ELE-080 | 7.8d | 0d | Electrician [160 h]; Common Labor / Helper [160 h] | 37,783.44 | 1.3.3.90 | CONS | CONS | ZONE-3 |  | ELEC |  | POWER |
| CONC-Z3-UTIL-ELE-120 |  | Energizing of MV Cables | 24d | 2017-07-25 | 2017-08-22 | CONC-Z3-UTIL-ELE-110 SS+3d, CONC-Z3-UTIL-ELE-080 | 7.8d | 0d | Electrician [104 h] | 75,566.88 | 1.3.3.90 | CONS | CONS | ZONE-3 |  | ELEC |  | POWER |
| CONC-Z3-UTIL-ELE-130 |  | Energizing of RMU'S Transformers and Unit Substations | 20d | 2017-07-31 | 2017-08-23 | CONC-Z3-UTIL-ELE-120 SS+5d, CONC-Z3-UTIL-ELE-110 SS+3d | 7.8d | 0d | Electrician [104 h] | 75,566.88 | 1.3.3.90 | CONS | CONS | ZONE-3 |  | ELEC |  | POWER |

Notes:
- CON-Z3-UTI-RD-R1-370: Expenses: (New Expense Item) 1081.77
- CON-Z3-UTI-RD-R1-380: Expenses: (New Expense Item) 3245.31
- CON-Z3-UTI-RD-R1-390: Expenses: (New Expense Item) 3245.31
- CON-Z3-UTI-RD-R1-400: Expenses: (New Expense Item) 1081.77
- CON-Z3-UTI-RD-R1-410: Expenses: (New Expense Item) 2163.54
- CON-Z3-UTI-RD-R1-420: Expenses: (New Expense Item) 3245.31
- CON-Z3-UTI-RD-R1-430: Expenses: (New Expense Item) 2163.54
- CON-Z3-UTI-RD-R1-440: Expenses: (New Expense Item) 3245.31
- CON-Z3-UTI-RD-R1-450: Expenses: (New Expense Item) 1081.77
- CON-Z3-UTI-RD-R1-460: Expenses: (New Expense Item) 649.06
- CON-Z3-UTI-RD-R1-470: Expenses: (New Expense Item) 432.71
- CON-Z3-UTI-RD-GE-010: Expenses: (New Expense Item) 19231.5
- CON-Z3-UT-ELE-TC-010: Expenses: (New Expense Item) 20000
- CONC-Z3-UTIL-ELE-010: Expenses: (New Expense Item) 55566.9
- CONC-Z3-UTIL-ELE-020: Expenses: (New Expense Item) 37783.4
- CONC-Z3-UTIL-ELE-030: Expenses: (New Expense Item) 113350
- CONC-Z3-UTIL-ELE-040: Expenses: (New Expense Item) 37783.4
- CONC-Z3-UTIL-ELE-050: Expenses: (New Expense Item) 15113.4
- CONC-Z3-UTIL-ELE-060: Expenses: (New Expense Item) 22670.1
- CONC-Z3-UTIL-ELE-070: Expenses: (New Expense Item) 75566.9
- CONC-Z3-UTIL-ELE-790: Expenses: (New Expense Item) 37783.4
- CONC-Z3-UTIL-ELE-080: Expenses: (New Expense Item) 75566.9
- CONC-Z3-UTIL-ELE-090: Expenses: (New Expense Item) 37783.4
- CONC-Z3-UTIL-ELE-100: Expenses: (New Expense Item) 37783.4
- CONC-Z3-UTIL-ELE-110: Expenses: (New Expense Item) 37783.4
- CONC-Z3-UTIL-ELE-120: Expenses: (New Expense Item) 75566.9
- CONC-Z3-UTIL-ELE-130: Expenses: (New Expense Item) 75566.9

| ID | WBS | Activity | Duration | Start | Finish | Predecessors | Total float | Free float | Resources | Cost | RPI_P2 - BOQ ITEMS | RPI_P2 - CONSTRUCTION | RPI_P2 - PHASE | RPI_P2 - ZONES | RPI_P2 - DISCIPLINE / WORK TYPE | RPI_P2 - UTILITY NETWORK |
| --- | --- | --- | --- | --- | --- | --- | --- | --- | --- | --- | --- | --- | --- | --- | --- | --- |
|  | 2 | **Remaining MV Cables,Transformers,RMU'S and Unit Sub Stations (Loop 6)** |  | 2016-11-19 | 2017-08-23 |  |  |  |  |  |  |  |  |  |  |  |
| CONC-Z3-UTIL-ELE-140 |  | Excavation and Cleaning for MV cable trench | 12d | 2016-11-19 | 2016-12-03 | CONC-Z3-UTIL-ELE-010 | 2.8d | 0d | Common Labor / Helper [624 h]; Operator - JCB [60 h]; JCB [60 h] | 75,566.88 | 1.3.3.90 | CONS | CONS | ZONE-3 | ELEC | POWER |
| CONC-Z3-UTIL-ELE-150 |  | Sand Bedding of MV Cable Trench | 8d | 2016-12-03 | 2016-12-12 | CONC-Z3-UTIL-ELE-140 | 82.8d | 71d | Common Labor / Helper [104 h]; Operator - Loader [26 h]; Driver - Dump Truck [26 h]; Operator - Bobcat [26 h]; Operator - JCB [26 h]; Loader [28 h]; Dump Truck [28 h]; Bobcat [28 h]; JCB [28 h] | 37,783.44 | 1.3.3.90 | CONS | CONS | ZONE-3 | ELEC | POWER |
| CONC-Z3-UTIL-ELE-160 |  | MV Cable Pulling | 16d | 2017-03-05 | 2017-03-23 | PR-Z3-EW-EW-36-0080, CONC-Z3-UTIL-ELE-150 | 11.8d | 0d | Electrician [78 h]; Common Labor / Helper [104 h]; Operator - Forklift [26 h]; Forklift [28 h] | 113,350.32 | 1.3.3.90 | CONS | CONS | ZONE-3 | ELEC | POWER |
| CONC-Z3-UTIL-ELE-170 |  | Splicing and Termination of MV Cables | 8d | 2017-03-23 | 2017-04-02 | CONC-Z3-UTIL-ELE-160, PR-Z3-EW-EW-37-0080 | 11.8d | 0d | Electrician [78 h]; Specialist Works Crew [26 h] | 37,783.44 | 1.3.3.90 | CONS | CONS | ZONE-3 | ELEC | POWER |
| CONC-Z3-UTIL-ELE-180 |  | Soft Sand Filling | 8d | 2017-04-02 | 2017-04-11 | CONC-Z3-UTIL-ELE-170 | 11.8d | 0d | Common Labor / Helper [104 h]; Driver - Water Tanker [26 h]; Operator - JCB [26 h]; Water Tanker [28 h]; JCB [28 h] | 15,113.38 | 1.3.3.90 | CONS | CONS | ZONE-3 | ELEC | POWER |
| CONC-Z3-UTIL-ELE-190 |  | Installation of Red Tiles and Warning Tape | 16d | 2017-04-11 | 2017-04-30 | CONC-Z3-UTIL-ELE-180, PR-Z3-EW-EW-40-0080 | 11.8d | 0d | Common Labor / Helper [78 h]; Block Mason [52 h]; Tiling Crew [52 h] | 22,670.06 | 1.3.3.90 | CONS | CONS | ZONE-3 | ELEC | POWER |
| CONC-Z3-UTIL-ELE-200 |  | Final Backfilling | 24d | 2017-05-01 | 2017-05-29 | CONC-Z3-UTIL-ELE-190 SS+17d | 11.8d | 0d | Common Labor / Helper [104 h]; Operator - Loader [26 h]; Driver - Dump Truck [26 h]; Operator - Bobcat [26 h]; Operator - Asphalt Compactor / Roller [26 h]; Operator - Roller-Compactor (2~10 Ton) [26 h]; Driver - Water Tanker [26 h]; Operator - JCB [26 h]; Loader [28 h]; Dump Truck [28 h]; Bobcat [28 h]; Roller-Compactor (2~10 Ton) [28 h]; Roller-Compactor (25 Ton) [28 h]; Water Tanker [28 h] | 75,566.88 | 1.3.3.90 | CONS | CONS | ZONE-3 | ELEC | POWER |
| CONC-Z3-UTIL-ELE-210 |  | Testing and Precommissioning of MV Cables | 20d | 2017-05-29 | 2017-06-21 | CONC-Z3-UTIL-ELE-200 | 11.8d | 0d | Electrician [78 h]; Common Labor / Helper [26 h] | 75,566.88 | 1.3.3.90 | CONS | CONS | ZONE-3 | ELEC | POWER |
| CONC-Z3-UTIL-ELE-800 |  | Instalaltion of Cable Markers | 4d | 2017-06-20 | 2017-06-25 | CONC-Z3-UTIL-ELE-200, CONC-Z3-UTIL-ELE-790, PR-Z3-EW-EW-47-0080 | 59.8d | 0d | Shuttering Carpenter [26 h]; Common Labor / Helper [78 h] | 37,783.44 | 1.3.3.90 | CONS | CONS | ZONE-3 | ELEC | POWER |
| CONC-Z3-UTIL-ELE-220 |  | Installation of Concrete Foundation for remaining RMU'S and Tranformers | 16d | 2017-06-21 | 2017-07-15 | CONC-Z3-UTIL-ELE-210 | 11.8d | 0d | Steel Fixer [52 h]; Shuttering Carpenter [78 h]; Concrete Mason [78 h]; Common Labor / Helper [52 h]; Driver - Conc. Transit Mixers [26 h]; Operator - Concrete Pump [26 h]; Concrete Transit Mixers [28 h]; Concrete Pump [28 h] | 37,783.44 | 1.3.3.90 | CONS | CONS | ZONE-3 | ELEC | POWER |
| CONC-Z3-UTIL-ELE-230 |  | Installation of RMU'S,Transformers and Unit Substations | 16d | 2017-07-15 | 2017-08-02 | CONC-Z3-UTIL-ELE-220 | 11.8d | 0d | Electrician [160 h]; Mechanical Technician [26 h]; HVAC Crew [26 h] | 37,783.44 | 1.3.3.90 | CONS | CONS | ZONE-3 | ELEC | POWER |
| CONC-Z3-UTIL-ELE-240 |  | Testing and Precommissioning of RMU'S Transformers and Unit Substations | 16d | 2017-07-18 | 2017-08-06 | CONC-Z3-UTIL-ELE-230 SS+3d, CONC-Z3-UTIL-ELE-210 | 11.8d | 0d | Electrician [160 h]; Common Labor / Helper [160 h] | 37,783.44 | 1.3.3.90 | CONS | CONS | ZONE-3 | ELEC | POWER |
| CONC-Z3-UTIL-ELE-250 |  | Energizing of MV Cables | 24d | 2017-07-22 | 2017-08-19 | CONC-Z3-UTIL-ELE-210, CONC-Z3-UTIL-ELE-240 SS+3d | 11.8d | 4d | Electrician [1200 h] | 75,566.88 | 1.3.3.90 | CONS | CONS | ZONE-3 | ELEC | POWER |
| CONC-Z3-UTIL-ELE-260 |  | Energizing of RMU'S Transformers and Unit Substations | 20d | 2017-07-31 | 2017-08-23 | CONC-Z3-UTIL-ELE-130 SS, CONC-Z3-UTIL-ELE-240 SS+3d, CONC-Z3-UTIL-ELE-250 SS+4d | 7.8d | 0d | Electrician [104 h] | 75,566.88 | 1.3.3.90 | CONS | CONS | ZONE-3 | ELEC | POWER |
|  | 3 | **Remaining MV Cables,Transformers,RMU'S and Unit Sub Stations (Loop 7)** |  | 2016-11-22 | 2017-08-23 |  |  |  |  |  |  |  |  |  |  |  |
| CONC-Z3-UTIL-ELE-270 |  | Excavation and Cleaning for MV cable trench | 10d | 2016-11-22 | 2016-12-04 | CONC-Z3-UTIL-ELE-140 SS+3d | 2.8d | 0d | Common Labor / Helper [520 h]; Operator - JCB [50 h]; JCB [50 h] | 75,566.88 | 1.3.3.90 | CONS | CONS | ZONE-3 | ELEC | POWER |
| CONC-Z3-UTIL-ELE-280 |  | Sand Bedding of MV Cable Trench | 8d | 2016-12-04 | 2016-12-13 | CONC-Z3-UTIL-ELE-270 | 23.8d | 0d | Common Labor / Helper [104 h]; Operator - Loader [26 h]; Driver - Dump Truck [26 h]; Operator - Bobcat [26 h]; Operator - JCB [26 h]; Loader [28 h]; Dump Truck [28 h]; Bobcat [28 h]; JCB [28 h] | 37,783.44 | 1.3.3.90 | CONS | CONS | ZONE-3 | ELEC | POWER |
| CONC-Z3-UTIL-ELE-290 |  | MV Cable Pulling | 16d | 2016-12-13 | 2017-01-01 | CONC-Z3-UTIL-ELE-280 | 23.8d | 0d | Electrician [78 h]; Common Labor / Helper [104 h]; Operator - Forklift [26 h]; Forklift [28 h] | 113,350.32 | 1.3.3.90 | CONS | CONS | ZONE-3 | ELEC | POWER |
| CONC-Z3-UTIL-ELE-300 |  | Splicing and Termination of MV Cables | 8d | 2017-01-01 | 2017-01-10 | CONC-Z3-UTIL-ELE-290 | 23.8d | 0d | Electrician [78 h]; Specialist Works Crew [26 h] | 37,783.44 | 1.3.3.90 | CONS | CONS | ZONE-3 | ELEC | POWER |
| CONC-Z3-UTIL-ELE-310 |  | Soft Sand Filling | 8d | 2017-01-10 | 2017-01-19 | CONC-Z3-UTIL-ELE-300 | 23.8d | 0d | Common Labor / Helper [104 h]; Driver - Water Tanker [26 h]; Operator - JCB [26 h]; Water Tanker [28 h]; JCB [28 h] | 15,113.38 | 1.3.3.90 | CONS | CONS | ZONE-3 | ELEC | POWER |
| CONC-Z3-UTIL-ELE-320 |  | Installation of Red Tiles and Warning Tape | 16d | 2017-01-19 | 2017-02-07 | CONC-Z3-UTIL-ELE-310 | 23.8d | 0d | Common Labor / Helper [78 h]; Block Mason [52 h]; Tiling Crew [52 h] | 22,670.06 | 1.3.3.90 | CONS | CONS | ZONE-3 | ELEC | POWER |
| CONC-Z3-UTIL-ELE-330 |  | Final Backfilling | 24d | 2017-02-07 | 2017-03-07 | CONC-Z3-UTIL-ELE-320 | 23.8d | 0d | Operator - JCB [26 h]; Loader [28 h]; Dump Truck [28 h]; Bobcat [28 h]; Roller-Compactor (2~10 Ton) [28 h]; Roller-Compactor (25 Ton) [28 h]; Water Tanker [28 h]; Common Labor / Helper [104 h]; Operator - Loader [26 h]; Driver - Dump Truck [26 h]; Operator - Bobcat [26 h]; Operator - Asphalt Compactor / Roller [26 h]; Operator - Roller-Compactor (2~10 Ton) [26 h]; Driver - Water Tanker [26 h] | 75,566.88 | 1.3.3.90 | CONS | CONS | ZONE-3 | ELEC | POWER |
| CONC-Z3-UTIL-ELE-340 |  | Testing and Precommissioning of MV Cables | 30d | 2017-03-25 | 2017-04-29 | CONC-Z3-UTIL-ELE-330 FS+15d | 23.8d | 0d | Electrician [78 h]; Common Labor / Helper [26 h] | 75,566.88 | 1.3.3.90 | CONS | CONS | ZONE-3 | ELEC | POWER |
| CONC-Z3-UTIL-ELE-350 |  | Installation of Concrete Foundation for remaining RMU'S and Tranformers | 16d | 2017-04-29 | 2017-05-17 | CONC-Z3-UTIL-ELE-340 | 23.8d | 0d | Steel Fixer [52 h]; Shuttering Carpenter [78 h]; Concrete Mason [78 h]; Common Labor / Helper [52 h]; Driver - Conc. Transit Mixers [26 h]; Operator - Concrete Pump [26 h]; Concrete Transit Mixers [28 h]; Concrete Pump [28 h] | 37,783.44 | 1.3.3.90 | CONS | CONS | ZONE-3 | ELEC | POWER |
| CONC-Z3-UTIL-ELE-360 |  | Installation of RMU'S,Transformers and Unit Substations | 16d | 2017-05-17 | 2017-06-05 | CONC-Z3-UTIL-ELE-350 | 23.8d | 0d | Electrician [78 h]; Mechanical Technician [26 h]; HVAC Crew [26 h] | 37,783.44 | 1.3.3.90 | CONS | CONS | ZONE-3 | ELEC | POWER |
| CONC-Z3-UTIL-ELE-370 |  | Testing and Precommissioning of RMU'S Transformers and Unit Substations | 16d | 2017-06-05 | 2017-06-24 | CONC-Z3-UTIL-ELE-360, CONC-Z3-UTIL-ELE-340 | 23.8d | 0d | Electrician [78 h]; Common Labor / Helper [26 h] | 37,783.44 | 1.3.3.90 | CONS | CONS | ZONE-3 | ELEC | POWER |
| CONC-Z3-UTIL-ELE-380 |  | Energizing of MV Cables | 24d | 2017-06-10 | 2017-07-12 | CONC-Z3-UTIL-ELE-340, CONC-Z3-UTIL-ELE-370 SS+4d | 23.8d | 16d | Electrician [104 h] | 75,566.88 | 1.3.3.90 | CONS | CONS | ZONE-3 | ELEC | POWER |
| CONC-Z3-UTIL-ELE-810 |  | Instalaltion of Cable Markers | 16d | 2017-06-25 | 2017-07-18 | CONC-Z3-UTIL-ELE-330, CONC-Z3-UTIL-ELE-800 | 59.8d | 0d | Shuttering Carpenter [26 h]; Common Labor / Helper [78 h] | 37,783.44 | 1.3.3.90 | CONS | CONS | ZONE-3 | ELEC | POWER |
| CONC-Z3-UTIL-ELE-390 |  | Energizing of RMU'S Transformers and Unit Substations | 20d | 2017-07-31 | 2017-08-23 | CONC-Z3-UTIL-ELE-380, CONC-Z3-UTIL-ELE-260 SS, CONC-Z3-UTIL-ELE-370 | 7.8d | 0d | Electrician [104 h] | 75,566.88 | 1.3.3.90 | CONS | CONS | ZONE-3 | ELEC | POWER |

Notes:
- CONC-Z3-UTIL-ELE-140: Expenses: (New Expense Item) 75566.9
- CONC-Z3-UTIL-ELE-150: Expenses: (New Expense Item) 37783.4
- CONC-Z3-UTIL-ELE-160: Expenses: (New Expense Item) 113350
- CONC-Z3-UTIL-ELE-170: Expenses: (New Expense Item) 37783.4
- CONC-Z3-UTIL-ELE-180: Expenses: (New Expense Item) 15113.4
- CONC-Z3-UTIL-ELE-190: Expenses: (New Expense Item) 22670.1
- CONC-Z3-UTIL-ELE-200: Expenses: (New Expense Item) 75566.9
- CONC-Z3-UTIL-ELE-210: Expenses: (New Expense Item) 75566.9
- CONC-Z3-UTIL-ELE-800: Expenses: (New Expense Item) 37783.4
- CONC-Z3-UTIL-ELE-220: Expenses: (New Expense Item) 37783.4
- CONC-Z3-UTIL-ELE-230: Expenses: (New Expense Item) 37783.4
- CONC-Z3-UTIL-ELE-240: Expenses: (New Expense Item) 37783.4
- CONC-Z3-UTIL-ELE-250: Expenses: (New Expense Item) 75566.9
- CONC-Z3-UTIL-ELE-260: Expenses: (New Expense Item) 75566.9
- CONC-Z3-UTIL-ELE-270: Expenses: (New Expense Item) 75566.9
- CONC-Z3-UTIL-ELE-280: Expenses: (New Expense Item) 37783.4
- CONC-Z3-UTIL-ELE-290: Expenses: (New Expense Item) 113350
- CONC-Z3-UTIL-ELE-300: Expenses: (New Expense Item) 37783.4
- CONC-Z3-UTIL-ELE-310: Expenses: (New Expense Item) 15113.4
- CONC-Z3-UTIL-ELE-320: Expenses: (New Expense Item) 22670.1
- CONC-Z3-UTIL-ELE-330: Expenses: (New Expense Item) 75566.9
- CONC-Z3-UTIL-ELE-340: Expenses: (New Expense Item) 75566.9
- CONC-Z3-UTIL-ELE-350: Expenses: (New Expense Item) 37783.4
- CONC-Z3-UTIL-ELE-360: Expenses: (New Expense Item) 37783.4
- CONC-Z3-UTIL-ELE-370: Expenses: (New Expense Item) 37783.4
- CONC-Z3-UTIL-ELE-380: Expenses: (New Expense Item) 75566.9
- CONC-Z3-UTIL-ELE-810: Expenses: (New Expense Item) 37783.4
- CONC-Z3-UTIL-ELE-390: Expenses: (New Expense Item) 75566.9

| ID | WBS | Activity | Duration | Start | Finish | Predecessors | Total float | Free float | Resources | Cost | RPI_P2 - BOQ ITEMS | RPI_P2 - CONSTRUCTION | RPI_P2 - PHASE | RPI_P2 - ZONES | RPI_P2 - DISCIPLINE / WORK TYPE | RPI_P2 - UTILITY NETWORK |
| --- | --- | --- | --- | --- | --- | --- | --- | --- | --- | --- | --- | --- | --- | --- | --- | --- |
|  | 4 | **Remaining MV Cables,Transformers,RMU'S and Unit Sub Stations (Loop 8)** |  | 2016-12-04 | 2017-08-23 |  |  |  |  |  |  |  |  |  |  |  |
| CONC-Z3-UTIL-ELE-400 |  | Excavation and Cleaning for MV cable trench | 12d | 2016-12-04 | 2016-12-18 | CONC-Z3-UTIL-ELE-270 | 2.8d | 0d | Common Labor / Helper [52 h]; Operator - JCB [26 h]; JCB [28 h] | 75,566.88 | 1.3.3.90 | CONS | CONS | ZONE-3 | ELEC | POWER |
| CONC-Z3-UTIL-ELE-410 |  | Sand Bedding of MV Cable Trench | 8d | 2016-12-18 | 2016-12-27 | CONC-Z3-UTIL-ELE-400 | 37.8d | 0d | Common Labor / Helper [104 h]; Operator - Loader [26 h]; Driver - Dump Truck [26 h]; Operator - Bobcat [26 h]; Operator - JCB [26 h]; Loader [28 h]; Dump Truck [28 h]; Bobcat [28 h]; JCB [28 h] | 37,783.44 | 1.3.3.90 | CONS | CONS | ZONE-3 | ELEC | POWER |
| CONC-Z3-UTIL-ELE-420 |  | MV Cable Pulling | 16d | 2016-12-27 | 2017-01-15 | CONC-Z3-UTIL-ELE-410 | 37.8d | 0d | Electrician [78 h]; Common Labor / Helper [104 h]; Operator - Forklift [26 h]; Forklift [28 h] | 113,350.32 | 1.3.3.90 | CONS | CONS | ZONE-3 | ELEC | POWER |
| CONC-Z3-UTIL-ELE-430 |  | Splicing and Termination of MV Cables | 8d | 2017-01-15 | 2017-01-24 | CONC-Z3-UTIL-ELE-420 | 37.8d | 0d | Electrician [78 h]; Specialist Works Crew [26 h] | 37,783.44 | 1.3.3.90 | CONS | CONS | ZONE-3 | ELEC | POWER |
| CONC-Z3-UTIL-ELE-440 |  | Soft Sand Filling | 8d | 2017-01-24 | 2017-02-02 | CONC-Z3-UTIL-ELE-430 | 37.8d | 0d | Common Labor / Helper [104 h]; Driver - Water Tanker [26 h]; Operator - JCB [26 h]; Water Tanker [28 h]; JCB [28 h] | 15,113.38 | 1.3.3.90 | CONS | CONS | ZONE-3 | ELEC | POWER |
| CONC-Z3-UTIL-ELE-450 |  | Installation of Red Tiles and Warning Tape | 16d | 2017-02-02 | 2017-02-21 | CONC-Z3-UTIL-ELE-440 | 37.8d | 0d | Common Labor / Helper [78 h]; Block Mason [52 h]; Tiling Crew [52 h] | 22,670.06 | 1.3.3.90 | CONS | CONS | ZONE-3 | ELEC | POWER |
| CONC-Z3-UTIL-ELE-460 |  | Final Backfilling | 24d | 2017-02-21 | 2017-03-21 | CONC-Z3-UTIL-ELE-450 | 37.8d | 0d | Common Labor / Helper [104 h]; Operator - Loader [26 h]; Driver - Dump Truck [26 h]; Operator - Bobcat [26 h]; Operator - Asphalt Compactor / Roller [26 h]; Operator - Roller-Compactor (2~10 Ton) [26 h]; Driver - Water Tanker [26 h]; Operator - JCB [26 h]; Loader [28 h]; Dump Truck [28 h]; Bobcat [28 h]; Roller-Compactor (2~10 Ton) [28 h]; Roller-Compactor (25 Ton) [28 h]; Water Tanker [28 h] | 75,566.88 | 1.3.3.90 | CONS | CONS | ZONE-3 | ELEC | POWER |
| CONC-Z3-UTIL-ELE-470 |  | Testing and Precommissioning of MV Cables | 20d | 2017-03-21 | 2017-04-13 | CONC-Z3-UTIL-ELE-460 | 37.8d | 0d | Electrician [78 h]; Common Labor / Helper [26 h] | 75,566.88 | 1.3.3.90 | CONS | CONS | ZONE-3 | ELEC | POWER |
| CONC-Z3-UTIL-ELE-480 |  | Installation of Concrete Foundation for remaining RMU'S and Tranformers | 16d | 2017-04-13 | 2017-05-02 | CONC-Z3-UTIL-ELE-470 | 37.8d | 0d | Steel Fixer [52 h]; Shuttering Carpenter [78 h]; Concrete Mason [78 h]; Common Labor / Helper [52 h]; Driver - Conc. Transit Mixers [26 h]; Operator - Concrete Pump [26 h]; Concrete Transit Mixers [28 h]; Concrete Pump [28 h] | 37,783.44 | 1.3.3.90 | CONS | CONS | ZONE-3 | ELEC | POWER |
| CONC-Z3-UTIL-ELE-490 |  | Installation of RMU'S,Transformers and Unit Substations | 16d | 2017-05-02 | 2017-05-21 | CONC-Z3-UTIL-ELE-480 | 37.8d | 0d | Electrician [78 h]; Mechanical Technician [26 h]; HVAC Crew [26 h] | 37,783.44 | 1.3.3.90 | CONS | CONS | ZONE-3 | ELEC | POWER |
| CONC-Z3-UTIL-ELE-500 |  | Testing and Precommissioning of RMU'S Transformers and Unit Substations | 16d | 2017-05-21 | 2017-06-08 | CONC-Z3-UTIL-ELE-490, CONC-Z3-UTIL-ELE-470 | 37.8d | 0d | Electrician [78 h]; Common Labor / Helper [26 h] | 37,783.44 | 1.3.3.90 | CONS | CONS | ZONE-3 | ELEC | POWER |
| CONC-Z3-UTIL-ELE-510 |  | Energizing of MV Cables | 24d | 2017-05-24 | 2017-06-21 | CONC-Z3-UTIL-ELE-470, CONC-Z3-UTIL-ELE-500 SS+3d | 37.8d | 30d | Electrician [104 h] | 75,566.88 | 1.3.3.90 | CONS | CONS | ZONE-3 | ELEC | POWER |
| CONC-Z3-UTIL-ELE-820 |  | Instalaltion of Cable Markers | 4d | 2017-07-18 | 2017-07-23 | CONC-Z3-UTIL-ELE-460, CONC-Z3-UTIL-ELE-810 | 59.8d | 0d | Shuttering Carpenter [26 h]; Common Labor / Helper [78 h] | 37,783.44 | 1.3.3.90 | CONS | CONS | ZONE-3 | ELEC | POWER |
| CONC-Z3-UTIL-ELE-520 |  | Energizing of RMU'S Transformers and Unit Substations | 20d | 2017-07-31 | 2017-08-23 | CONC-Z3-UTIL-ELE-500, CONC-Z3-UTIL-ELE-510, CONC-Z3-UTIL-ELE-390 SS | 7.8d | 0d | Electrician [104 h] | 75,566.88 | 1.3.3.90 | CONS | CONS | ZONE-3 | ELEC | POWER |
|  | 5 | **Remaining MV Cables,Transformers,RMU'S and Unit Sub Stations (Loop 9)** |  | 2016-12-18 | 2017-08-23 |  |  |  |  |  |  |  |  |  |  |  |
| CONC-Z3-UTIL-ELE-530 |  | Excavation and Cleaning for MV cable trench | 12d | 2016-12-18 | 2017-01-01 | CONC-Z3-UTIL-ELE-400 | 2.8d | 0d | Common Labor / Helper [52 h]; Operator - JCB [26 h]; JCB [28 h] | 75,566.88 | 1.3.3.90 | CONS | CONS | ZONE-3 | ELEC | POWER |
| CONC-Z3-UTIL-ELE-540 |  | Sand Bedding of MV Cable Trench | 8d | 2017-01-01 | 2017-01-10 | CONC-Z3-UTIL-ELE-530 | 16.8d | 0d | Common Labor / Helper [104 h]; Operator - Loader [26 h]; Driver - Dump Truck [26 h]; Operator - Bobcat [26 h]; Operator - JCB [26 h]; Loader [28 h]; Dump Truck [28 h]; Bobcat [28 h]; JCB [28 h] | 37,783.44 | 1.3.3.90 | CONS | CONS | ZONE-3 | ELEC | POWER |
| CONC-Z3-UTIL-ELE-550 |  | MV Cable Pulling | 16d | 2017-01-10 | 2017-01-29 | CONC-Z3-UTIL-ELE-540 | 16.8d | 0d | Electrician [78 h]; Common Labor / Helper [104 h]; Operator - Forklift [26 h]; Forklift [28 h] | 113,350.32 | 1.3.3.90 | CONS | CONS | ZONE-3 | ELEC | POWER |
| CONC-Z3-UTIL-ELE-560 |  | Splicing and Termination of MV Cables | 8d | 2017-01-29 | 2017-02-07 | CONC-Z3-UTIL-ELE-550 | 16.8d | 0d | Electrician [78 h]; Specialist Works Crew [26 h] | 37,783.44 | 1.3.3.90 | CONS | CONS | ZONE-3 | ELEC | POWER |
| CONC-Z3-UTIL-ELE-570 |  | Soft Sand Filling | 8d | 2017-02-07 | 2017-02-16 | CONC-Z3-UTIL-ELE-560 | 16.8d | 0d | Common Labor / Helper [104 h]; Driver - Water Tanker [26 h]; Operator - JCB [26 h]; Water Tanker [28 h]; JCB [28 h] | 15,113.38 | 1.3.3.90 | CONS | CONS | ZONE-3 | ELEC | POWER |
| CONC-Z3-UTIL-ELE-580 |  | Installation of Red Tiles and Warning Tape | 16d | 2017-02-16 | 2017-03-07 | CONC-Z3-UTIL-ELE-570 | 16.8d | 0d | Common Labor / Helper [78 h]; Block Mason [52 h]; Tiling Crew [52 h] | 22,670.06 | 1.3.3.90 | CONS | CONS | ZONE-3 | ELEC | POWER |
| CONC-Z3-UTIL-ELE-590 |  | Final Backfilling | 35d | 2017-03-07 | 2017-04-17 | CONC-Z3-UTIL-ELE-580 | 16.8d | 0d | Common Labor / Helper [104 h]; Operator - Loader [26 h]; Driver - Dump Truck [26 h]; Operator - Bobcat [26 h]; Operator - Asphalt Compactor / Roller [26 h]; Operator - Roller-Compactor (2~10 Ton) [26 h]; Driver - Water Tanker [26 h]; Operator - JCB [26 h]; Loader [28 h]; Dump Truck [28 h]; Bobcat [28 h]; Roller-Compactor (2~10 Ton) [28 h]; Roller-Compactor (25 Ton) [28 h]; Water Tanker [28 h] | 75,566.88 | 1.3.3.90 | CONS | CONS | ZONE-3 | ELEC | POWER |
| CONC-Z3-UTIL-ELE-600 |  | Testing and Precommissioning of MV Cables | 20d | 2017-04-30 | 2017-05-23 | CONC-Z3-UTIL-ELE-590 FS+11d | 16.8d | 0d | Electrician [78 h]; Common Labor / Helper [26 h] | 75,566.88 | 1.3.3.90 | CONS | CONS | ZONE-3 | ELEC | POWER |
| CONC-Z3-UTIL-ELE-610 |  | Installation of Concrete Foundation for remaining RMU'S and Tranformers | 16d | 2017-05-23 | 2017-06-11 | CONC-Z3-UTIL-ELE-600 | 16.8d | 0d | Steel Fixer [52 h]; Shuttering Carpenter [78 h]; Concrete Mason [78 h]; Common Labor / Helper [52 h]; Driver - Conc. Transit Mixers [26 h]; Operator - Concrete Pump [26 h]; Concrete Transit Mixers [28 h]; Concrete Pump [28 h] | 37,783.44 | 1.3.3.90 | CONS | CONS | ZONE-3 | ELEC | POWER |
| CONC-Z3-UTIL-ELE-620 |  | Installation of RMU'S,Transformers and Unit Substations | 16d | 2017-05-27 | 2017-06-14 | CONC-Z3-UTIL-ELE-610 SS+3d | 16.8d | 0d | Electrician [78 h]; Mechanical Technician [26 h]; HVAC Crew [26 h] | 37,783.44 | 1.3.3.90 | CONS | CONS | ZONE-3 | ELEC | POWER |
| CONC-Z3-UTIL-ELE-630 |  | Testing and Precommissioning of RMU'S Transformers and Unit Substations | 16d | 2017-06-14 | 2017-07-08 | CONC-Z3-UTIL-ELE-620, CONC-Z3-UTIL-ELE-600 | 16.8d | 0d | Electrician [78 h]; Common Labor / Helper [26 h] | 37,783.44 | 1.3.3.90 | CONS | CONS | ZONE-3 | ELEC | POWER |
| CONC-Z3-UTIL-ELE-640 |  | Energizing of MV Cables | 24d | 2017-06-18 | 2017-07-20 | CONC-Z3-UTIL-ELE-600, CONC-Z3-UTIL-ELE-630 SS+3d | 16.8d | 9d | Electrician [104 h] | 75,566.88 | 1.3.3.90 | CONS | CONS | ZONE-3 | ELEC | POWER |
| CONC-Z3-UTIL-ELE-830 |  | Instalaltion of Cable Markers | 4d | 2017-07-23 | 2017-07-27 | CONC-Z3-UTIL-ELE-820, CONC-Z3-UTIL-ELE-590 | 59.8d | 0d | Shuttering Carpenter [26 h]; Common Labor / Helper [78 h] | 37,783.44 | 1.3.3.90 | CONS | CONS | ZONE-3 | ELEC | POWER |
| CONC-Z3-UTIL-ELE-650 |  | Energizing of RMU'S Transformers and Unit Substations | 20d | 2017-07-31 | 2017-08-23 | CONC-Z3-UTIL-ELE-520 SS, CONC-Z3-UTIL-ELE-640, CONC-Z3-UTIL-ELE-630 | 7.8d | 5d | Electrician [104 h] | 75,566.88 | 1.3.3.90 | CONS | CONS | ZONE-3 | ELEC | POWER |

Notes:
- CONC-Z3-UTIL-ELE-400: Expenses: (New Expense Item) 75566.9
- CONC-Z3-UTIL-ELE-410: Expenses: (New Expense Item) 37783.4
- CONC-Z3-UTIL-ELE-420: Expenses: (New Expense Item) 113350
- CONC-Z3-UTIL-ELE-430: Expenses: (New Expense Item) 37783.4
- CONC-Z3-UTIL-ELE-440: Expenses: (New Expense Item) 15113.4
- CONC-Z3-UTIL-ELE-450: Expenses: (New Expense Item) 22670.1
- CONC-Z3-UTIL-ELE-460: Expenses: (New Expense Item) 75566.9
- CONC-Z3-UTIL-ELE-470: Expenses: (New Expense Item) 75566.9
- CONC-Z3-UTIL-ELE-480: Expenses: (New Expense Item) 37783.4
- CONC-Z3-UTIL-ELE-490: Expenses: (New Expense Item) 37783.4
- CONC-Z3-UTIL-ELE-500: Expenses: (New Expense Item) 37783.4
- CONC-Z3-UTIL-ELE-510: Expenses: (New Expense Item) 75566.9
- CONC-Z3-UTIL-ELE-820: Expenses: (New Expense Item) 37783.4
- CONC-Z3-UTIL-ELE-520: Expenses: (New Expense Item) 75566.9
- CONC-Z3-UTIL-ELE-530: Expenses: (New Expense Item) 75566.9
- CONC-Z3-UTIL-ELE-540: Expenses: (New Expense Item) 37783.4
- CONC-Z3-UTIL-ELE-550: Expenses: (New Expense Item) 113350
- CONC-Z3-UTIL-ELE-560: Expenses: (New Expense Item) 37783.4
- CONC-Z3-UTIL-ELE-570: Expenses: (New Expense Item) 15113.4
- CONC-Z3-UTIL-ELE-580: Expenses: (New Expense Item) 22670.1
- CONC-Z3-UTIL-ELE-590: Expenses: (New Expense Item) 75566.9
- CONC-Z3-UTIL-ELE-600: Expenses: (New Expense Item) 75566.9
- CONC-Z3-UTIL-ELE-610: Expenses: (New Expense Item) 37783.4
- CONC-Z3-UTIL-ELE-620: Expenses: (New Expense Item) 37783.4
- CONC-Z3-UTIL-ELE-630: Expenses: (New Expense Item) 37783.4
- CONC-Z3-UTIL-ELE-640: Expenses: (New Expense Item) 75566.9
- CONC-Z3-UTIL-ELE-830: Expenses: (New Expense Item) 37783.4
- CONC-Z3-UTIL-ELE-650: Expenses: (New Expense Item) 75566.9

| ID | WBS | Activity | Duration | Start | Finish | Predecessors | Total float | Free float | Resources | Cost | RPI_P2 - BOQ ITEMS | RPI_P2 - CONSTRUCTION | RPI_P2 - PHASE | RPI_P2 - ZONES | RPI_P2 - DISCIPLINE / WORK TYPE | RPI_P2 - UTILITY NETWORK | Activity Wt% | Weight % | Cost Wt | RPI - PHASE | RPI - CONSTRUCTION | RPI - ZONES | RPI - UTILITY NETWORKS | RPI - TYPE OF WORK | RPI_P2 - AREAS |
| --- | --- | --- | --- | --- | --- | --- | --- | --- | --- | --- | --- | --- | --- | --- | --- | --- | --- | --- | --- | --- | --- | --- | --- | --- | --- |
|  | 6 | **Remaining MV Cables,Transformers,RMU'S and Unit Sub Stations (Loop 11)** |  | 2017-01-01 | 2017-08-29 |  |  |  |  |  |  |  |  |  |  |  |  |  |  |  |  |  |  |  |  |
| CONC-Z3-UTIL-ELE-660 |  | Excavation and Cleaning for MV cable trench | 12d | 2017-01-01 | 2017-01-15 | CONC-Z3-UTIL-ELE-530 | 2.8d | 0d | Common Labor / Helper [52 h]; Operator - JCB [26 h]; JCB [28 h] | 66,676.66 | 1.3.3.90 | CONS | CONS | ZONE-3 | ELEC | POWER |  |  |  |  |  |  |  |  |  |
| CONC-Z3-UTIL-ELE-670 |  | Sand Bedding of MV Cable Trench | 8d | 2017-01-15 | 2017-01-24 | CONC-Z3-UTIL-ELE-660 | 2.8d | 0d | Common Labor / Helper [104 h]; Operator - Loader [26 h]; Driver - Dump Truck [26 h]; Operator - Bobcat [26 h]; Operator - JCB [26 h]; Loader [28 h]; Dump Truck [28 h]; Bobcat [28 h]; JCB [28 h] | 33,338.33 | 1.3.3.90 | CONS | CONS | ZONE-3 | ELEC | POWER |  |  |  |  |  |  |  |  |  |
| CONC-Z3-UTIL-ELE-680 |  | MV Cable Pulling | 16d | 2017-01-24 | 2017-02-12 | CONC-Z3-UTIL-ELE-670 | 2.8d | 0d | Electrician [78 h]; Common Labor / Helper [104 h]; Operator - Forklift [26 h]; Forklift [28 h] | 100,014.99 | 1.3.3.90 | CONS | CONS | ZONE-3 | ELEC | POWER |  |  |  |  |  |  |  |  |  |
| CONC-Z3-UTIL-ELE-690 |  | Splicing and Termination of MV Cables | 8d | 2017-02-12 | 2017-02-21 | CONC-Z3-UTIL-ELE-680 | 2.8d | 0d | Electrician [78 h]; Specialist Works Crew [26 h] | 33,338.33 | 1.3.3.90 | CONS | CONS | ZONE-3 | ELEC | POWER |  |  |  |  |  |  |  |  |  |
| CONC-Z3-UTIL-ELE-700 |  | Soft Sand Filling | 8d | 2017-02-21 | 2017-03-02 | CONC-Z3-UTIL-ELE-690 | 2.8d | 0d | Common Labor / Helper [104 h]; Driver - Water Tanker [26 h]; Operator - JCB [26 h]; Water Tanker [28 h]; JCB [28 h] | 13,335.33 | 1.3.3.90 | CONS | CONS | ZONE-3 | ELEC | POWER |  |  |  |  |  |  |  |  |  |
| CONC-Z3-UTIL-ELE-710 |  | Installation of Red Tiles and Warning Tape | 16d | 2017-03-02 | 2017-03-21 | CONC-Z3-UTIL-ELE-700 | 2.8d | 0d | Common Labor / Helper [78 h]; Block Mason [52 h]; Tiling Crew [52 h] | 20,003 | 1.3.3.90 | CONS | CONS | ZONE-3 | ELEC | POWER |  |  |  |  |  |  |  |  |  |
| CONC-Z3-UTIL-ELE-720 |  | Final Backfilling | 24d | 2017-03-21 | 2017-04-18 | CONC-Z3-UTIL-ELE-710 | 2.8d | 0d | Common Labor / Helper [104 h]; Operator - Loader [26 h]; Driver - Dump Truck [26 h]; Operator - Bobcat [26 h]; Operator - Asphalt Compactor / Roller [26 h]; Operator - Roller-Compactor (2~10 Ton) [26 h]; Driver - Water Tanker [26 h]; Operator - JCB [26 h]; Loader [28 h]; Dump Truck [28 h]; Bobcat [28 h]; Roller-Compactor (2~10 Ton) [28 h]; Roller-Compactor (25 Ton) [28 h]; Water Tanker [28 h] | 66,676.66 | 1.3.3.90 | CONS | CONS | ZONE-3 | ELEC | POWER |  |  |  |  |  |  |  |  |  |
| CONC-Z3-UTIL-ELE-730 |  | Testing and Precommissioning of MV Cables | 20d | 2017-05-01 | 2017-05-24 | CONC-Z3-UTIL-ELE-720 FS+11d | 2.8d | 0d | Electrician [78 h]; Common Labor / Helper [26 h] | 66,676.66 | 1.3.3.90 | CONS | CONS | ZONE-3 | ELEC | POWER |  |  |  |  |  |  |  |  |  |
| CONC-Z3-UTIL-ELE-740 |  | Installation of Concrete Foundation for remaining RMU'S and Tranformers | 16d | 2017-05-24 | 2017-06-12 | CONC-Z3-UTIL-ELE-730 | 2.8d | 0d | Driver - Conc. Transit Mixers [26 h]; Operator - Concrete Pump [26 h]; Concrete Transit Mixers [28 h]; Concrete Pump [28 h]; Steel Fixer [52 h]; Shuttering Carpenter [78 h]; Concrete Mason [78 h]; Common Labor / Helper [52 h] | 33,338.33 | 1.3.3.90 | CONS | CONS | ZONE-3 | ELEC | POWER |  |  |  |  |  |  |  |  |  |
| CONC-Z3-UTIL-ELE-750 |  | Installation of RMU'S,Transformers and Unit Substations | 16d | 2017-06-12 | 2017-07-05 | CONC-Z3-UTIL-ELE-740 | 2.8d | 0d | Electrician [78 h]; Mechanical Technician [26 h]; HVAC Crew [26 h] | 33,338.33 | 1.3.3.90 | CONS | CONS | ZONE-3 | ELEC | POWER |  |  |  |  |  |  |  |  |  |
| CONC-Z3-UTIL-ELE-760 |  | Testing and Precommissioning of RMU'S Transformers and Unit Substations | 16d | 2017-07-05 | 2017-07-24 | CONC-Z3-UTIL-ELE-750, CONC-Z3-UTIL-ELE-730 | 2.8d | 0d | Electrician [160 h]; Common Labor / Helper [160 h] | 33,338.33 | 1.3.3.90 | CONS | CONS | ZONE-3 | ELEC | POWER |  |  |  |  |  |  |  |  |  |
| CONC-Z3-UTIL-ELE-770 |  | Energizing of MV Cables | 24d | 2017-07-09 | 2017-08-06 | CONC-Z3-UTIL-ELE-760 SS+3d, CONC-Z3-UTIL-ELE-730 | 2.8d | 0d | Electrician [240 h] | 66,676.66 | 1.3.3.90 | CONS | CONS | ZONE-3 | ELEC | POWER |  |  |  |  |  |  |  |  |  |
| CONC-Z3-UTIL-ELE-840 |  | Instalaltion of Cable Markers | 4d | 2017-07-27 | 2017-08-01 | CONC-Z3-UTIL-ELE-830, CONC-Z3-UTIL-ELE-720 | 59.8d | 25.8d | Shuttering Carpenter [26 h]; Common Labor / Helper [78 h] | 33,338.33 | 1.3.3.90 | CONS | CONS | ZONE-3 | ELEC | POWER |  |  |  |  |  |  |  |  |  |
| CONC-Z3-UTIL-ELE-780 |  | Energizing of RMU'S Transformers and Unit Substations | 20d | 2017-08-06 | 2017-08-29 | CONC-Z3-UTIL-ELE-760, CONC-Z3-UTIL-ELE-650 SS, CONC-Z3-UTIL-ELE-770 | 2.8d | 0d | Electrician [104 h] | 66,676.66 | 1.3.3.90 | CONS | CONS | ZONE-3 | ELEC | POWER |  |  |  |  |  |  |  |  |  |
|  | 7 | **Street Lighting** |  | 2017-01-01 | 2017-08-30 |  |  |  |  |  |  |  |  |  |  |  |  |  |  |  |  |  |  |  |  |
|  | 3 | **Road A** |  | 2017-01-01 | 2017-06-18 |  |  |  |  |  |  |  |  |  |  |  |  |  |  |  |  |  |  |  |  |
|  | 1 | **Remaining LV cable Laying for Street Lighting** |  | 2017-01-01 | 2017-02-02 |  |  |  |  |  |  |  |  |  |  |  |  |  |  |  |  |  |  |  |  |
| CON-Z3-UTI-EL-SL-010 |  | Excavation and Cleaning of Street Lighting Trench (436 Lm) | 5d | 2017-01-01 | 2017-01-07 | CON-Z3-UT-ELE-TC-010 SS, CON-CON-CON-CON-0010 FS+120d | 34d | 0d | Common Labor / Helper [104 h]; Operator - JCB [26 h]; JCB [28 h] | 40,006 | 1.3.3.90 | CONS | CONS | ZONE-3 | ELEC | POWER | 0 | 0 | 0.0481453262 | 6 | RPI - CONS | Z2 | POWER | ELEC | ROAD-A |
| CON-Z3-UTI-EL-SL-020 |  | Bed Preparation | 3.2d | 2017-01-07 | 2017-01-10 | CON-Z3-UTI-EL-SL-010 SS+4.8d | 34d | 0d | Common Labor / Helper [104 h]; Operator - Roller-Compactor (2~10 Ton) [26 h]; Driver - Water Tanker [26 h]; Water Tanker [28 h] | 13,335.33 | 1.3.3.90 | CONS | CONS | ZONE-3 | ELEC | POWER | 0 | 0 | 0.0120363316 | 6 | RPI - CONS | Z2 | POWER | ELEC | ROAD-A |
| CON-Z3-UTI-EL-SL-030 |  | Sand Bedding | 3.2d | 2017-01-12 | 2017-01-16 | CON-Z3-UTI-EL-SL-020 SS+5.6d | 34d | 0d | Common Labor / Helper [104 h]; Operator - Loader [26 h]; Driver - Dump Truck [26 h]; Operator - Bobcat [26 h]; Operator - JCB [26 h]; Loader [28 h]; Dump Truck [28 h]; Bobcat [28 h]; JCB [28 h] | 13,335.33 | 1.3.3.90 | CONS | CONS | ZONE-3 | ELEC | POWER | 0 | 0 | 0.0120363316 | 6 | RPI - CONS | Z2 | POWER | ELEC | ROAD-A |
| CON-Z3-UTI-EL-SL-040 |  | Laying of LV Cables (1890 Lm) | 8d | 2017-01-12 | 2017-01-22 | CON-Z3-UTI-EL-SL-030 SS | 34d | 0d | Electrician [78 h]; Common Labor / Helper [52 h] | 80,011.99 | 1.3.3.90 | CONS | CONS | ZONE-3 | ELEC | POWER | 0 | 0 | 0.0842543209 | 6 | RPI - CONS | Z2 | POWER | ELEC | ROAD-A |
| CON-Z3-UTI-EL-SL-050 |  | Sand filling above Cables | 4d | 2017-01-12 | 2017-01-17 | CON-Z3-UTI-EL-SL-040 SS | 34d | 0d | Common Labor / Helper [104 h]; Driver - Water Tanker [26 h]; Operator - JCB [26 h]; Water Tanker [28 h]; JCB [28 h] | 13,335.33 | 1.3.3.90 | CONS | CONS | ZONE-3 | ELEC | POWER | 0 | 0 | 0.0120363316 | 6 | RPI - CONS | Z2 | POWER | ELEC | ROAD-A |
| CON-Z3-UTI-EL-SL-060 |  | Installation of Red Tiles | 8d | 2017-01-14 | 2017-01-23 | CON-Z3-UTI-EL-SL-050 SS+0.8d | 34d | 0d | Common Labor / Helper [78 h]; Block Mason [52 h]; Tiling Crew [52 h] | 53,341.33 | 1.3.3.90 | CONS | CONS | ZONE-3 | ELEC | POWER | 0 | 0 | 0.0120363316 | 6 | RPI - CONS | Z2 | POWER | ELEC | ROAD-A |
| CON-Z3-UTI-EL-SL-070 |  | Backfilling for Trenches | 9.6d | 2017-01-23 | 2017-02-02 | CON-Z3-UTI-EL-SL-060 | 34d | 0d | Common Labor / Helper [104 h]; Operator - Loader [26 h]; Driver - Dump Truck [26 h]; Operator - Bobcat [26 h]; Operator - Asphalt Compactor / Roller [26 h]; Operator - Roller-Compactor (2~10 Ton) [26 h]; Driver - Water Tanker [26 h]; Operator - JCB [26 h]; Loader [28 h]; Dump Truck [28 h]; Bobcat [28 h]; Roller-Compactor (2~10 Ton) [28 h]; Roller-Compactor (25 Ton) [28 h]; Water Tanker [28 h] | 53,341.33 | 1.3.3.90 | CONS | CONS | ZONE-3 | ELEC | POWER | 0 | 0 | 0.0481453262 | 6 | RPI - CONS | Z2 | POWER | ELEC | ROAD-A |

Notes:
- CONC-Z3-UTIL-ELE-660: Expenses: (New Expense Item) 66676.7
- CONC-Z3-UTIL-ELE-670: Expenses: (New Expense Item) 33338.3
- CONC-Z3-UTIL-ELE-680: Expenses: (New Expense Item) 100015
- CONC-Z3-UTIL-ELE-690: Expenses: (New Expense Item) 33338.3
- CONC-Z3-UTIL-ELE-700: Expenses: (New Expense Item) 13335.3
- CONC-Z3-UTIL-ELE-710: Expenses: (New Expense Item) 20003
- CONC-Z3-UTIL-ELE-720: Expenses: (New Expense Item) 66676.7
- CONC-Z3-UTIL-ELE-730: Expenses: (New Expense Item) 66676.7
- CONC-Z3-UTIL-ELE-740: Expenses: (New Expense Item) 33338.3
- CONC-Z3-UTIL-ELE-750: Expenses: (New Expense Item) 33338.3
- CONC-Z3-UTIL-ELE-760: Expenses: (New Expense Item) 33338.3
- CONC-Z3-UTIL-ELE-770: Expenses: (New Expense Item) 66676.7
- CONC-Z3-UTIL-ELE-840: Expenses: (New Expense Item) 33338.3
- CONC-Z3-UTIL-ELE-780: Expenses: (New Expense Item) 66676.7
- CON-Z3-UTI-EL-SL-010: Expenses: (New Expense Item) 40006
- CON-Z3-UTI-EL-SL-020: Expenses: (New Expense Item) 13335.3
- CON-Z3-UTI-EL-SL-030: Expenses: (New Expense Item) 13335.3
- CON-Z3-UTI-EL-SL-040: Expenses: (New Expense Item) 80012
- CON-Z3-UTI-EL-SL-050: Expenses: (New Expense Item) 13335.3
- CON-Z3-UTI-EL-SL-060: Expenses: (New Expense Item) 53341.3
- CON-Z3-UTI-EL-SL-070: Expenses: (New Expense Item) 53341.3

| ID | WBS | Activity | Duration | Start | Finish | Predecessors | Total float | Free float | Resources | Cost | Activity Wt% | Weight % | Cost Wt | RPI - PHASE | RPI - CONSTRUCTION | RPI - ZONES | RPI - UTILITY NETWORKS | RPI - TYPE OF WORK | RPI_P2 - BOQ ITEMS | RPI_P2 - CONSTRUCTION | RPI_P2 - PHASE | RPI_P2 - ZONES | RPI_P2 - AREAS | RPI_P2 - DISCIPLINE / WORK TYPE | RPI_P2 - UTILITY NETWORK |
| --- | --- | --- | --- | --- | --- | --- | --- | --- | --- | --- | --- | --- | --- | --- | --- | --- | --- | --- | --- | --- | --- | --- | --- | --- | --- |
|  | 2 | **Remaining Installation & Termination of Lighting Poles and Lighting Fixures** |  | 2017-03-25 | 2017-06-18 |  |  |  |  |  |  |  |  |  |  |  |  |  |  |  |  |  |  |  |  |
| CON-Z3-UTI-EL-SL-080 |  | Excavation for Concrete Foundations for Lighting Poles (10 no.) | 3d | 2017-03-25 | 2017-03-28 | PR-Z3-EW-EW-58-0080, CON-Z3-UTI-EL-SL-010, CON-Z3-UTI-EL-SL-040 FS+9.6d | 73d | 0d | Common Labor / Helper [26 h]; Operator - JCB [26 h]; JCB [28 h] | 60,008.99 | 0 | 0 | 0.1811862394 | 6 | RPI - CONS | Z2 | POWER | ELEC | 1.3.3.90 | CONS | CONS | ZONE-3 | ROAD-A | ELEC | POWER |
| CON-Z3-UTI-EL-SL-090 |  | Instalaltion of Precast Concrete Foundations for Lighting Poles (10 no.) | 1.6d | 2017-03-28 | 2017-03-29 | CON-Z3-UTI-EL-SL-080 | 73d | 0d | Common Labor / Helper [52 h]; Operator - Mobile Crane [26 h]; Mobile Crane ( 25-60 Ton) [28 h] | 100,014.99 | 0 | 0 | 0.5435587182 | 6 | RPI - CONS | Z2 | POWER | ELEC | 1.3.3.90 | CONS | CONS | ZONE-3 | ROAD-A | ELEC | POWER |
| CON-Z3-UTI-EL-SL-100 |  | Instalaltion of Lighting Poles (17 no.) | 4d | 2017-03-30 | 2017-04-03 | CON-Z3-UTI-EL-SL-090 | 73d | 0d | Electrician [26 h]; Operator - Mobile Crane [26 h]; Mobile Crane ( 25-60 Ton) [28 h] | 100,014.99 |  |  |  |  |  |  |  |  | 1.3.3.90 | CONS | CONS | ZONE-3 | ROAD-A | ELEC | POWER |
| CON-Z3-UTI-EL-SL-110 |  | Backfilling around Lighting Poles Foundations | 8d | 2017-05-03 | 2017-05-11 | CON-Z3-UTI-EL-SL-100 FS+25d | 73d | 0d | Common Labor / Helper [52 h]; Driver - Dump Truck [26 h]; Operator - Bobcat [26 h]; Operator - Roller-Compactor (2~10 Ton) [26 h]; Driver - Water Tanker [26 h]; Operator - JCB [26 h]; Loader [28 h]; Dump Truck [28 h]; Bobcat [28 h]; Roller-Compactor (2~10 Ton) [28 h]; Roller-Compactor (25 Ton) [28 h]; Water Tanker [28 h] | 20,003 | 0 | 0 | 0.0958716073 | 6 | RPI - CONS | Z2 | POWER | ELEC | 1.3.3.90 | CONS | CONS | ZONE-3 | ROAD-A | ELEC | POWER |
| CON-Z3-UTI-EL-SL-120 |  | Installation of Lighting Fixures/Luminaries (41 no.) | 8d | 2017-05-13 | 2017-05-21 | CON-Z3-UTI-EL-SL-110 | 73d | 0d | Electrician [104 h]; LC Crew [52 h]; Operator - Manlift (Boom Truck) [26 h]; Manlift (Boom Truck) [28 h] | 40,006 |  |  |  |  |  |  |  |  | 1.3.3.90 | CONS | CONS | ZONE-3 | ROAD-A | ELEC | POWER |
| CON-Z3-UTI-EL-SL-130 |  | Street Lighting Termination and Testing of Lighting Poles (100 no.) | 24d | 2017-05-22 | 2017-06-18 | CON-Z3-UTI-EL-SL-120 | 73d | 0d | Electrician [104 h]; LC Crew [52 h] | 80,011.99 |  |  |  |  |  |  |  |  | 1.3.3.90 | CONS | CONS | ZONE-3 | ROAD-A | ELEC | POWER |
|  | 1 | **Road B** |  | 2017-03-11 | 2017-07-04 |  |  |  |  |  |  |  |  |  |  |  |  |  |  |  |  |  |  |  |  |
|  | 1 | **Rectification and Reinstatement of LV Cable Laying for Lighting Poles** |  | 2017-03-11 | 2017-04-13 |  |  |  |  |  |  |  |  |  |  |  |  |  |  |  |  |  |  |  |  |
| CON-Z3-UTI-EL-SL-200 |  | Rectification and Reinstatement of LV Cable Laying including Red Tiles,Warning Tape and Final Backfilling | 30d | 2017-03-11 | 2017-04-13 | CON-Z3-UTI-EL-SL-070 FS+30d, CON-Z3-UTI-EL-SL-010 | 34d | 0d | Electrician [52 h]; Common Labor / Helper [130 h]; Operator - Loader [26 h]; Driver - Dump Truck [26 h]; Operator - Bobcat [26 h]; Operator - Roller-Compactor (2~10 Ton) [26 h]; Driver - Water Tanker [26 h]; Operator - JCB [26 h]; Loader [28 h]; Dump Truck [28 h]; Bobcat [28 h]; Roller-Compactor (2~10 Ton) [28 h]; Plate Compactor [28 h]; Vibrators [28 h]; Water Tanker [28 h]; JCB [28 h] | 74,085.18 | 0 | 0 | 0.0481453262 | 6 | RPI - CONS | Z2 | POWER | ELEC | 1.3.3.90 | CONS | CONS | ZONE-3 | ROAD-B | ELEC | POWER |
|  | 2 | **Remaining Installation & Termination of Lighting Poles and Lighting Fixures** |  | 2017-05-02 | 2017-07-04 |  |  |  |  |  |  |  |  |  |  |  |  |  |  |  |  |  |  |  |  |
| CON-Z3-UTI-EL-SL-140 |  | Excavation for Concrete Foundations for Lighting Poles (2 no.) | 0.8d | 2017-05-02 | 2017-05-02 | CON-Z3-UTI-EL-SL-080, PR-Z3-EW-EW-58-0080, CON-Z3-UTI-EL-SL-200 FS+15d | 106.8d | 0d | Common Labor / Helper [26 h]; Operator - JCB [26 h]; JCB [28 h] | 44,451.11 | 0 | 0 | 0.1811862394 | 6 | RPI - CONS | Z2 | POWER | ELEC | 1.3.3.90 | CONS | CONS | ZONE-3 | ROAD-B | ELEC | POWER |
| CON-Z3-UTI-EL-SL-150 |  | Instalaltion of Precast Concrete Foundations for Lighting Poles (2 no.) | 0.8d | 2017-05-02 | 2017-05-03 | CON-Z3-UTI-EL-SL-140 | 106.8d | 0d | Common Labor / Helper [52 h]; Operator - Mobile Crane [26 h]; Mobile Crane ( 25-60 Ton) [28 h] | 74,085.18 | 0 | 0 | 0.5435587182 | 6 | RPI - CONS | Z2 | POWER | ELEC | 1.3.3.90 | CONS | CONS | ZONE-3 | ROAD-B | ELEC | POWER |
| CON-Z3-UTI-EL-SL-160 |  | Instalaltion of Lighting Poles (2 no.) | 0.8d | 2017-05-03 | 2017-05-04 | CON-Z3-UTI-EL-SL-150 | 106.8d | 0d | Electrician [26 h]; Operator - Mobile Crane [26 h]; Mobile Crane ( 25-60 Ton) [28 h] | 74,085.18 |  |  |  |  |  |  |  |  | 1.3.3.90 | CONS | CONS | ZONE-3 | ROAD-B | ELEC | POWER |
| CON-Z3-UTI-EL-SL-170 |  | Backfilling around Lighting Poles Foundations | 4d | 2017-05-04 | 2017-05-09 | CON-Z3-UTI-EL-SL-160 | 106.8d | 0d | Common Labor / Helper [52 h]; Driver - Dump Truck [26 h]; Operator - Bobcat [26 h]; Operator - Roller-Compactor (2~10 Ton) [26 h]; Driver - Water Tanker [26 h]; Operator - JCB [26 h]; Loader [28 h]; Dump Truck [28 h]; Bobcat [28 h]; Roller-Compactor (2~10 Ton) [28 h]; Roller-Compactor (25 Ton) [28 h]; Water Tanker [28 h] | 14,817.04 | 0 | 0 | 0.0958716073 | 6 | RPI - CONS | Z2 | POWER | ELEC | 1.3.3.90 | CONS | CONS | ZONE-3 | ROAD-B | ELEC | POWER |
| CON-Z3-UTI-EL-SL-180 |  | Installation of Lighting Fixures/Luminaries (2 no.) | 0.8d | 2017-05-09 | 2017-05-10 | CON-Z3-UTI-EL-SL-170 | 106.8d | 33.8d | Electrician [104 h]; LC Crew [52 h]; Operator - Manlift (Boom Truck) [26 h]; Manlift (Boom Truck) [28 h] | 29,634.07 |  |  |  |  |  |  |  |  | 1.3.3.90 | CONS | CONS | ZONE-3 | ROAD-B | ELEC | POWER |
| CON-Z3-UTI-EL-SL-190 |  | Street Lighting Termination and Testing of Lighting Poles (36 no.) | 10d | 2017-06-19 | 2017-07-04 | CON-Z3-UTI-EL-SL-180, CON-Z3-UTI-EL-SL-130 | 73d | 39d | Electrician [104 h]; LC Crew [52 h] | 59,268.14 |  |  |  |  |  |  |  |  | 1.3.3.90 | CONS | CONS | ZONE-3 | ROAD-B | ELEC | POWER |
|  | 2 | **Road 3** |  | 2017-05-02 | 2017-08-19 |  |  |  |  |  |  |  |  |  |  |  |  |  |  |  |  |  |  |  |  |
|  | 1 | **Rectification and Reinstatement of LV Cable Laying for Lighting Poles** |  | 2017-05-02 | 2017-06-05 |  |  |  |  |  |  |  |  |  |  |  |  |  |  |  |  |  |  |  |  |
| CON-Z3-UTI-EL-SL-270 |  | Rectification and Reinstatement of LV Cable Laying including Red Tiles,Warning Tape and Final Backfilling | 30d | 2017-05-02 | 2017-06-05 | CON-Z3-UTI-EL-SL-200 FS+15d | 34d | 0d | Electrician [52 h]; Common Labor / Helper [130 h]; Operator - Loader [26 h]; Driver - Dump Truck [26 h]; Operator - Bobcat [26 h]; Operator - Roller-Compactor (2~10 Ton) [26 h]; Driver - Water Tanker [26 h]; Operator - JCB [26 h]; Loader [28 h]; Dump Truck [28 h]; Bobcat [28 h]; Roller-Compactor (2~10 Ton) [28 h]; Roller-Compactor (25 Ton) [28 h]; Water Tanker [28 h] | 29,634.07 | 0 | 0 | 0.0481453262 | 6 | RPI - CONS | Z2 | POWER | ELEC | 1.3.3.90 | CONS | CONS | ZONE-3 | ROAD-3 | ELEC | POWER |
|  | 2 | **Remaining Installation & Termination of Lighting Poles and Lighting Fixures** |  | 2017-06-06 | 2017-08-19 |  |  |  |  |  |  |  |  |  |  |  |  |  |  |  |  |  |  |  |  |
| CON-Z3-UTI-EL-SL-220 |  | Excavation for Concrete Foundations for Lighting Poles | 10d | 2017-06-06 | 2017-06-17 | CON-Z3-UTI-EL-SL-270 | 34d | 0d | Common Labor / Helper [26 h]; Operator - JCB [26 h]; JCB [28 h] | 17,780.44 | 0 | 0 | 0.1811862394 | 6 | RPI - CONS | Z2 | POWER | ELEC | 1.3.3.90 | CONS | CONS | ZONE-3 | ROAD-3 | ELEC | POWER |
| CON-Z3-UTI-EL-SL-230 |  | Instalaltion of Precast Concrete Foundations for Lighting Poles | 10d | 2017-06-18 | 2017-07-03 | CON-Z3-UTI-EL-SL-220 | 34d | 0d | Common Labor / Helper [52 h]; Operator - Mobile Crane [26 h]; Mobile Crane ( 25-60 Ton) [28 h] | 29,634.07 | 0 | 0 | 0.5435587182 | 6 | RPI - CONS | Z2 | POWER | ELEC | 1.3.3.90 | CONS | CONS | ZONE-3 | ROAD-3 | ELEC | POWER |
| CON-Z3-UTI-EL-SL-240 |  | Instalaltion of Lighting Poles | 10d | 2017-07-04 | 2017-07-15 | CON-Z3-UTI-EL-SL-230 | 34d | 0d | Electrician [100 h]; Operator - Mobile Crane [100 h]; Mobile Crane ( 25-60 Ton) [140 h] | 29,634.07 |  |  |  |  |  |  |  |  | 1.3.3.90 | CONS | CONS | ZONE-3 | ROAD-3 | ELEC | POWER |
| CON-Z3-UTI-EL-SL-600 |  | Backfilling around Lighting Poles Foundations | 10d | 2017-07-16 | 2017-07-26 | CON-Z3-UTI-EL-SL-240 | 34d | 0d | Operator - Roller-Compactor (2~10 Ton) [26 h]; Driver - Water Tanker [26 h]; Operator - JCB [26 h]; Loader [28 h]; Dump Truck [28 h]; Bobcat [28 h]; Roller-Compactor (2~10 Ton) [28 h]; Roller-Compactor (25 Ton) [28 h]; Water Tanker [28 h]; Common Labor / Helper [52 h]; Driver - Dump Truck [26 h]; Operator - Bobcat [26 h] | 23,707.26 | 0 | 0 | 0.0958716073 | 6 | RPI - CONS | Z2 | POWER | ELEC | 1.3.3.90 | CONS | CONS | ZONE-3 | ROAD-3 | ELEC | POWER |
| CON-Z3-UTI-EL-SL-250 |  | Installation of Lighting Fixures/Luminaries | 10d | 2017-07-27 | 2017-08-07 | CON-Z3-UTI-EL-SL-600 | 34d | 0d | Electrician [104 h]; LC Crew [52 h]; Operator - Manlift (Boom Truck) [26 h]; Manlift (Boom Truck) [28 h] | 5,926.81 |  |  |  |  |  |  |  |  | 1.3.3.90 | CONS | CONS | ZONE-3 | ROAD-3 | ELEC | POWER |
| CON-Z3-UTI-EL-SL-260 |  | Street Lighting Termination and Testing of Lighting Poles | 10d | 2017-08-08 | 2017-08-19 | CON-Z3-UTI-EL-SL-250, CON-Z3-UTI-EL-SL-190 SS | 34d | 0d | Electrician [104 h]; LC Crew [52 h] | 11,853.63 |  |  |  |  |  |  |  |  | 1.3.3.90 | CONS | CONS | ZONE-3 | ROAD-3 | ELEC | POWER |

Notes:
- CON-Z3-UTI-EL-SL-080: Expenses: (New Expense Item) 60009
- CON-Z3-UTI-EL-SL-090: Expenses: (New Expense Item) 100015
- CON-Z3-UTI-EL-SL-100: Expenses: (New Expense Item) 100015
- CON-Z3-UTI-EL-SL-110: Expenses: (New Expense Item) 20003
- CON-Z3-UTI-EL-SL-120: Expenses: (New Expense Item) 40006
- CON-Z3-UTI-EL-SL-130: Expenses: (New Expense Item) 80012
- CON-Z3-UTI-EL-SL-200: Expenses: (New Expense Item) 74085.2
- CON-Z3-UTI-EL-SL-140: Expenses: (New Expense Item) 44451.1
- CON-Z3-UTI-EL-SL-150: Expenses: (New Expense Item) 74085.2
- CON-Z3-UTI-EL-SL-160: Expenses: (New Expense Item) 74085.2
- CON-Z3-UTI-EL-SL-170: Expenses: (New Expense Item) 14817
- CON-Z3-UTI-EL-SL-180: Expenses: (New Expense Item) 29634.1
- CON-Z3-UTI-EL-SL-190: Expenses: (New Expense Item) 59268.1
- CON-Z3-UTI-EL-SL-270: Expenses: (New Expense Item) 29634.1
- CON-Z3-UTI-EL-SL-220: Expenses: (New Expense Item) 17780.4
- CON-Z3-UTI-EL-SL-230: Expenses: (New Expense Item) 29634.1
- CON-Z3-UTI-EL-SL-240: Expenses: (New Expense Item) 29634.1
- CON-Z3-UTI-EL-SL-600: Expenses: (New Expense Item) 23707.3
- CON-Z3-UTI-EL-SL-250: Expenses: (New Expense Item) 5926.81
- CON-Z3-UTI-EL-SL-260: Expenses: (New Expense Item) 11853.6

| ID | WBS | Activity | Duration | Start | Finish | Predecessors | Total float | Free float | Resources | Cost | Activity Wt% | Weight % | Cost Wt | RPI - PHASE | RPI - CONSTRUCTION | RPI - ZONES | RPI - UTILITY NETWORKS | RPI - TYPE OF WORK | RPI_P2 - BOQ ITEMS | RPI_P2 - CONSTRUCTION | RPI_P2 - PHASE | RPI_P2 - ZONES | RPI_P2 - AREAS | RPI_P2 - DISCIPLINE / WORK TYPE | RPI_P2 - UTILITY NETWORK | Wajid |
| --- | --- | --- | --- | --- | --- | --- | --- | --- | --- | --- | --- | --- | --- | --- | --- | --- | --- | --- | --- | --- | --- | --- | --- | --- | --- | --- |
|  | 4 | **Road 2** |  | 2017-06-06 | 2017-08-30 |  |  |  |  |  |  |  |  |  |  |  |  |  |  |  |  |  |  |  |  |  |
|  | 1 | **Rectification and Reinstatement of LV Cable Laying for Lighting Poles** |  | 2017-06-06 | 2017-07-15 |  |  |  |  |  |  |  |  |  |  |  |  |  |  |  |  |  |  |  |  |  |
| CON-Z3-UTI-EL-SL-340 |  | Rectification and Reinstatement of LV Cable Laying including Red Tiles,Warning Tape and Final Backfilling | 30d | 2017-06-06 | 2017-07-15 | CON-Z3-UTI-EL-SL-270 | 50.2d | 0d | Electrician [52 h]; Common Labor / Helper [130 h]; Operator - Loader [26 h]; Driver - Dump Truck [26 h]; Operator - Bobcat [26 h]; Operator - Roller-Compactor (2~10 Ton) [26 h]; Driver - Water Tanker [26 h]; Operator - JCB [26 h]; Loader [28 h]; Dump Truck [28 h]; Bobcat [28 h]; Roller-Compactor (2~10 Ton) [28 h]; Roller-Compactor (25 Ton) [28 h]; Water Tanker [28 h] | 29,634.07 | 0 | 0 | 0.0481453262 | 6 | RPI - CONS | Z2 | POWER | ELEC | 1.3.3.90 | CONS | CONS | ZONE-3 | ROAD-2 | ELEC | POWER |  |
|  | 2 | **Remaining Installation & Termination of Lighting Poles and Lighting Fixures** |  | 2017-07-16 | 2017-08-30 |  |  |  |  |  |  |  |  |  |  |  |  |  |  |  |  |  |  |  |  |  |
| CON-Z3-UTI-EL-SL-290 |  | Excavation for Concrete Foundations for Lighting Poles | 3d | 2017-07-16 | 2017-07-18 | CON-Z3-UTI-EL-SL-340 | 50.2d | 0d | Common Labor / Helper [26 h]; Operator - JCB [26 h]; JCB [28 h] | 29,634.07 | 0 | 0 | 0.1811862394 | 6 | RPI - CONS | Z2 | POWER | ELEC | 1.3.3.90 | CONS | CONS | ZONE-3 | ROAD-2 | ELEC | POWER |  |
| CON-Z3-UTI-EL-SL-300 |  | Instalaltion of Precast Concrete Foundations for Lighting Poles | 3d | 2017-07-19 | 2017-07-22 | CON-Z3-UTI-EL-SL-290 | 50.2d | 0d | Common Labor / Helper [52 h]; Operator - Mobile Crane [26 h]; Mobile Crane ( 25-60 Ton) [28 h] | 29,634.07 | 0 | 0 | 0.5435587182 | 6 | RPI - CONS | Z2 | POWER | ELEC | 1.3.3.90 | CONS | CONS | ZONE-3 | ROAD-2 | ELEC | POWER |  |
| CON-Z3-UTI-EL-SL-310 |  | Instalaltion of Lighting Poles | 3d | 2017-07-23 | 2017-07-25 | CON-Z3-UTI-EL-SL-300 | 50.2d | 0d | Electrician [26 h]; Operator - Mobile Crane [26 h]; Mobile Crane ( 25-60 Ton) [28 h] | 5,926.81 |  |  |  |  |  |  |  |  | 1.3.3.90 | CONS | CONS | ZONE-3 | ROAD-2 | ELEC | POWER |  |
| CON-Z3-UTI-EL-SL-280 |  | Backfilling around Lighting Poles Foundations | 4d | 2017-07-26 | 2017-07-30 | CON-Z3-UTI-EL-SL-310 | 50.2d | 0d | Common Labor / Helper [52 h]; Driver - Dump Truck [26 h]; Operator - Bobcat [26 h]; Operator - Roller-Compactor (2~10 Ton) [26 h]; Driver - Water Tanker [26 h]; Operator - JCB [26 h]; Loader [28 h]; Dump Truck [28 h]; Bobcat [28 h]; Roller-Compactor (2~10 Ton) [28 h]; Roller-Compactor (25 Ton) [28 h]; Water Tanker [28 h] | 17,780.44 | 0 | 0 | 0.0958716073 | 6 | RPI - CONS | Z2 | POWER | ELEC | 1.3.3.90 | CONS | CONS | ZONE-3 | ROAD-2 | ELEC | POWER |  |
| CON-Z3-UTI-EL-SL-320 |  | Installation of Lighting Fixures/Luminaries | 0.8d | 2017-07-31 | 2017-07-31 | CON-Z3-UTI-EL-SL-280 | 50.2d | 16.2d | Electrician [8 h]; LC Crew [52 h]; Operator - Manlift (Boom Truck) [26 h]; Manlift (Boom Truck) [28 h] | 11,853.63 |  |  |  |  |  |  |  |  | 1.3.3.90 | CONS | CONS | ZONE-3 | ROAD-2 | ELEC | POWER |  |
| CON-Z3-UTI-EL-SL-330 |  | Street Lighting Termination and Testing of Lighting Poles | 10d | 2017-08-20 | 2017-08-30 | CON-Z3-UTI-EL-SL-320, CON-Z3-UTI-EL-SL-260 | 34d | 0d | Electrician [104 h]; LC Crew [52 h] | 23,707.26 |  |  |  |  |  |  |  |  | 1.3.3.90 | CONS | CONS | ZONE-3 | ROAD-2 | ELEC | POWER |  |
|  | 5 | **Road 4** |  | 2017-07-16 | 2017-08-30 |  |  |  |  |  |  |  |  |  |  |  |  |  |  |  |  |  |  |  |  |  |
|  | 1 | **Rectification and Reinstatement of LV Cable Laying for Lighting Poles** |  | 2017-07-16 | 2017-08-19 |  |  |  |  |  |  |  |  |  |  |  |  |  |  |  |  |  |  |  |  |  |
| CON-Z3-UTI-EL-SL-410 |  | Rectification and Reinstatement of LV Cable Laying including Red Tiles,Warning Tape and Final Backfilling | 30d | 2017-07-16 | 2017-08-19 | CON-Z3-UTI-EL-SL-340 | 55d | 0d | Electrician [52 h]; Common Labor / Helper [130 h]; Operator - Loader [26 h]; Driver - Dump Truck [26 h]; Operator - Bobcat [26 h]; Operator - Roller-Compactor (2~10 Ton) [26 h]; Driver - Water Tanker [26 h]; Operator - JCB [26 h]; Loader [28 h]; Dump Truck [28 h]; Bobcat [28 h]; Roller-Compactor (2~10 Ton) [28 h]; Roller-Compactor (25 Ton) [28 h]; Water Tanker [28 h] | 29,634.07 | 0 | 0 | 0.0481453262 | 6 | RPI - CONS | Z2 | POWER | ELEC | 1.3.3.90 | CONS | CONS | ZONE-3 | ROAD-4 | ELEC | POWER |  |
|  | 2 | **Remaining Installation & Termination of Lighting Poles and Lighting Fixures** |  | 2017-07-18 | 2017-08-30 |  |  |  |  |  |  |  |  |  |  |  |  |  |  |  |  |  |  |  |  |  |
| CON-Z3-UTI-EL-SL-360 |  | Excavation for Concrete Foundations for Lighting Poles | 3d | 2017-07-18 | 2017-07-20 | CON-Z3-UTI-EL-SL-410 SS+2d | 55d | 0d | Common Labor / Helper [26 h]; Operator - JCB [26 h]; JCB [28 h] | 29,634.07 | 0 | 0 | 0.1811862394 | 6 | RPI - CONS | Z2 | POWER | ELEC | 1.3.3.90 | CONS | CONS | ZONE-3 | ROAD-4 | ELEC | POWER |  |
| CON-Z3-UTI-EL-SL-370 |  | Instalaltion of Precast Concrete Foundations for Lighting Poles | 3d | 2017-07-22 | 2017-07-24 | CON-Z3-UTI-EL-SL-360 | 55d | 0d | Common Labor / Helper [52 h]; Operator - Mobile Crane [26 h]; Mobile Crane ( 25-60 Ton) [28 h] | 29,634.07 | 0 | 0 | 0.5435587182 | 6 | RPI - CONS | Z2 | POWER | ELEC | 1.3.3.90 | CONS | CONS | ZONE-3 | ROAD-4 | ELEC | POWER |  |
| CON-Z3-UTI-EL-SL-380 |  | Instalaltion of Lighting Poles | 3d | 2017-07-24 | 2017-07-26 | CON-Z3-UTI-EL-SL-370 SS+2d | 55d | 2d | Electrician [26 h]; Operator - Mobile Crane [26 h]; Mobile Crane ( 25-60 Ton) [28 h] | 5,926.81 |  |  |  |  |  |  |  |  | 1.3.3.90 | CONS | CONS | ZONE-3 | ROAD-4 | ELEC | POWER |  |
| CON-Z3-UTI-EL-SL-350 |  | Backfilling around Lighting Poles Foundations | 4d | 2017-07-26 | 2017-07-30 | CON-Z3-UTI-EL-SL-280 SS | 53d | 0d | Common Labor / Helper [52 h]; Driver - Dump Truck [26 h]; Operator - Bobcat [26 h]; Operator - Roller-Compactor (2~10 Ton) [26 h]; Driver - Water Tanker [26 h]; Operator - JCB [26 h]; Loader [28 h]; Dump Truck [28 h]; Bobcat [28 h]; Roller-Compactor (2~10 Ton) [28 h]; Roller-Compactor (25 Ton) [28 h]; Water Tanker [28 h] | 17,780.44 | 0 | 0 | 0.0958716073 | 6 | RPI - CONS | Z2 | POWER | ELEC | 1.3.3.90 | CONS | CONS | ZONE-3 | ROAD-4 | ELEC | POWER |  |
| CON-Z3-UTI-EL-SL-390 |  | Installation of Lighting Fixures/Luminaries | 0.8d | 2017-07-26 | 2017-07-26 | CON-Z3-UTI-EL-SL-350 SS, CON-Z3-UTI-EL-SL-380 SS | 53d | 19d | Operator - Manlift (Boom Truck) [26 h]; Manlift (Boom Truck) [28 h]; Electrician [104 h]; LC Crew [52 h] | 11,853.63 |  |  |  |  |  |  |  |  | 1.3.3.90 | CONS | CONS | ZONE-3 | ROAD-4 | ELEC | POWER |  |
| CON-Z3-UTI-EL-SL-400 |  | Street Lighting Termination and Testing of Lighting Poles | 10d | 2017-08-20 | 2017-08-30 | CON-Z3-UTI-EL-SL-390 SS+2d, CON-Z3-UTI-EL-SL-330 SS | 34d | 0d | Electrician [104 h]; LC Crew [52 h] | 23,707.26 |  |  |  |  |  |  |  |  | 1.3.3.90 | CONS | CONS | ZONE-3 | ROAD-4 | ELEC | POWER |  |
|  | 9 | **Communication & Security Systems** |  | 2016-12-25 | 2017-11-01 |  |  |  |  |  |  |  |  |  |  |  |  |  |  |  |  |  |  |  |  |  |
|  | 1 | **Fiber Optic and Copper Cabling System** |  | 2017-05-01 | 2017-10-26 |  |  |  |  |  |  |  |  |  |  |  |  |  |  |  |  |  |  |  |  |  |
|  | 1 | **FOC - Fiber Optics & Copper Cabling Works** |  | 2017-05-01 | 2017-10-26 |  |  |  |  |  |  |  |  |  |  |  |  |  |  |  |  |  |  |  |  |  |
| CON-Z3-UTIL-COM-0010 |  | Installation of Sub-ducts for FOC & Copper Cables | 60d | 2017-05-01 | 2017-07-15 | CON-Z1-UTIL-COM-0010 FS+1.2d, PR-Z3-CW-CS-91-0090 FS+90d | 0.4d | 0d |  | 612,285.16 |  |  |  |  |  |  |  |  | 1.3.3.100 | CONS | CONS | ZONE-3 |  | COMM | COMM | OK |
| CON-Z3-UTIL-COM-0020 |  | Pulling of FOC - Fiber Optic & Copper Cables | 48d | 2017-07-15 | 2017-09-13 | CON-Z3-UTIL-COM-0010 | 18.6d | 0d |  | 1,224,570.32 |  |  |  |  |  |  |  |  | 1.3.3.100 | CONS | CONS | ZONE-3 |  | COMM | COMM | OK |
| CON-Z3-UTIL-COM-0030 |  | Splicing and termination of FOC & Copper Cables | 36d | 2017-09-13 | 2017-10-26 | CON-Z3-UTIL-COM-0020 | 18.6d | 0d |  | 612,285.16 |  |  |  |  |  |  |  |  | 1.3.3.100 | CONS | CONS | ZONE-3 |  | COMM | COMM | OK |
| CON-Z3-UTIL-COM-0040 |  | Testing & Pre-Commissioning of FOC and Copper Cables | 30d | 2017-09-17 | 2017-10-23 | CON-Z3-UTIL-COM-1600, CON-Z3-UTIL-COM-1830 FF, CON-Z3-UTIL-COM-0030 SS+3d, CON-Z3-UTIL-COM-1780 FF, CON-Z3-UTIL-COM-1730 FF, CON-Z3-UTIL-COM-1550 | 18.6d | 15.8d |  | 612,285.16 |  |  |  |  |  |  |  |  | 1.3.3.100 | CONS | CONS | ZONE-3 |  | COMM | COMM | OK |

Notes:
- CON-Z3-UTI-EL-SL-340: Expenses: (New Expense Item) 29634.1
- CON-Z3-UTI-EL-SL-290: Expenses: (New Expense Item) 29634.1
- CON-Z3-UTI-EL-SL-300: Expenses: (New Expense Item) 29634.1
- CON-Z3-UTI-EL-SL-310: Expenses: (New Expense Item) 5926.81
- CON-Z3-UTI-EL-SL-280: Expenses: (New Expense Item) 17780.4
- CON-Z3-UTI-EL-SL-320: Expenses: (New Expense Item) 11853.6
- CON-Z3-UTI-EL-SL-330: Expenses: (New Expense Item) 23707.3
- CON-Z3-UTI-EL-SL-410: Expenses: (New Expense Item) 29634.1
- CON-Z3-UTI-EL-SL-360: Expenses: (New Expense Item) 29634.1
- CON-Z3-UTI-EL-SL-370: Expenses: (New Expense Item) 29634.1
- CON-Z3-UTI-EL-SL-380: Expenses: (New Expense Item) 5926.81
- CON-Z3-UTI-EL-SL-350: Expenses: (New Expense Item) 17780.4
- CON-Z3-UTI-EL-SL-390: Expenses: (New Expense Item) 11853.6
- CON-Z3-UTI-EL-SL-400: Expenses: (New Expense Item) 23707.3
- CON-Z3-UTIL-COM-0010: Expenses: (New Expense Item) 612285
- CON-Z3-UTIL-COM-0020: Expenses: (New Expense Item) 1224570
- CON-Z3-UTIL-COM-0030: Expenses: (New Expense Item) 612285
- CON-Z3-UTIL-COM-0040: Expenses: (New Expense Item) 612285

| ID | WBS | Activity | Duration | Start | Finish | Predecessors | Total float | Free float | Resources | Cost | Wajid | RPI_P2 - BOQ ITEMS | RPI_P2 - CONSTRUCTION | RPI_P2 - PHASE | RPI_P2 - ZONES | RPI_P2 - DISCIPLINE / WORK TYPE | RPI_P2 - UTILITY NETWORK |
| --- | --- | --- | --- | --- | --- | --- | --- | --- | --- | --- | --- | --- | --- | --- | --- | --- | --- |
|  | 2 | **Communication & Security Systems** |  | 2017-05-02 | 2017-11-01 |  |  |  |  |  |  |  |  |  |  |  |  |
|  | 1 | **CCTV System** |  | 2017-05-15 | 2017-11-01 |  |  |  |  |  |  |  |  |  |  |  |  |
|  | 1 | **External Cabling For CCTV System** |  | 2017-05-15 | 2017-10-18 |  |  |  |  |  |  |  |  |  |  |  |  |
|  | 1 | **LV Power Cables (Direct Burried) For Camera** |  | 2017-05-15 | 2017-10-18 |  |  |  |  |  |  |  |  |  |  |  |  |
| CON-Z4-UTIL-COM-400 |  | Excavation for LV Cable Trench for Camera | 48d | 2017-05-15 | 2017-07-15 | CON-Z3-UTIL-COM-0010 SS+12d | 0.4d | 0d |  | 59,273.09 | OK | 1.3.3.100 | CONS | CONS | ZONE-3 | COMM | COMM |
| CON-Z4-UTIL-COM-410 |  | Compaction and Sand bedding for LV Cable Trench for Camera | 26d | 2017-06-13 | 2017-07-18 | CON-Z4-UTIL-COM-400 SS+25d | 19.6d | 0d |  | 59,273.09 | OK | 1.3.3.100 | CONS | CONS | ZONE-3 | COMM | COMM |
| CON-Z4-UTIL-COM-420 |  | Instalaltion of LV Cables for Camera | 30d | 2017-07-18 | 2017-08-22 | CON-Z4-UTIL-COM-410 | 19.6d | 0d |  | 177,819.26 | OK | 1.3.3.100 | CONS | CONS | ZONE-3 | COMM | COMM |
| CON-Z4-UTIL-COM-430 |  | Sand Backfilling for Code Blue LV Cable Trench | 45d | 2017-07-25 | 2017-09-20 | CON-Z4-UTIL-COM-420 SS+6d | 32.6d | 0d |  | 29,636.54 | OK | 1.3.3.100 | CONS | CONS | ZONE-3 | COMM | COMM |
| CON-Z4-UTIL-COM-440 |  | Installation of Red Tiles and Warning Tape | 45d | 2017-07-29 | 2017-09-25 | CON-Z4-UTIL-COM-430 SS+3d | 32.6d | 0d |  | 118,546.17 | OK | 1.3.3.100 | CONS | CONS | ZONE-3 | COMM | COMM |
| CON-Z4-UTIL-COM-450 |  | Final Backfilling | 60d | 2017-08-03 | 2017-10-18 | CON-Z4-UTIL-COM-440 SS+5d | 32.6d | 13d | JCB [1800 h]; Bobcat [1800 h]; Vibrators [2400 h]; Dump Truck [2400 h]; Operator - JCB [1800 h]; Operator - Bobcat [1800 h]; Driver - Water Tanker [1200 h]; Driver - Dump Truck [2400 h]; Water Tanker [1200 h] | 59,273.09 | OK | 1.3.3.100 | CONS | CONS | ZONE-3 | COMM | COMM |
| CON-Z4-UTIL-COM-580 |  | Testing and Precommissioning of LV Cables for Camera | 26d | 2017-08-22 | 2017-09-27 | CON-Z4-UTIL-COM-450 SS+3d, CON-Z4-UTIL-COM-420 | 19.6d | 19.2d |  | 88,909.63 | OK | 1.3.3.100 | CONS | CONS | ZONE-3 | COMM | COMM |
|  | 2 | **Manholes and Duct Banks** |  | 2017-05-23 | 2017-08-06 |  |  |  |  |  |  |  |  |  |  |  |  |
| CON-Z4-UTIL-COM-570 |  | Remaining Works for Construction of Communication Manholes & Duct Banks | 60d | 2017-05-23 | 2017-08-06 | CON-Z4-UTIL-COM-400 SS+7d | 0.4d | 0d |  | 296,365.44 | OK | 1.3.3.100 | CONS | CONS | ZONE-3 | COMM | COMM |
|  | 3 | **Installation of Foundations for Pole of CCTV Camera** |  | 2017-06-06 | 2017-07-19 |  |  |  |  |  |  |  |  |  |  |  |  |
| CON-Z4-UTIL-COM-460 |  | Excavation of Foundations for Pole of CCTV Camera | 18d | 2017-06-06 | 2017-07-02 | CON-Z4-UTIL-COM-400 SS+2.4d, CON-Z4-UTIL-COM-570 SS+12d | 0.4d | 0d |  | 118,546.17 | OK | 1.3.3.100 | CONS | CONS | ZONE-3 | COMM | COMM |
| CON-Z4-UTIL-COM-470 |  | Compaction and Lean Concrete | 21d | 2017-06-08 | 2017-07-08 | CON-Z4-UTIL-COM-460 SS+2.4d | 0.4d | 0d |  | 59,273.09 | OK | 1.3.3.100 | CONS | CONS | ZONE-3 | COMM | COMM |
| CON-Z4-UTIL-COM-480 |  | Concrete Work for Foundations With Anchor Bolts | 16d | 2017-06-12 | 2017-07-05 | CON-Z4-UTIL-COM-470 SS+2.4d | 0.4d | 0d |  | 237,092.35 | OK | 1.3.3.100 | CONS | CONS | ZONE-3 | COMM | COMM |
| CON-Z4-UTIL-COM-490 |  | Installation of Poles for CCTV Camera | 26d | 2017-06-14 | 2017-07-19 | CON-Z4-UTIL-COM-480 SS+2.4d | 0.4d | 0d |  | 177,819.26 | OK | 1.3.3.100 | CONS | CONS | ZONE-3 | COMM | COMM |
|  | 4 | **Installation of Field Equipment Cabinet (FEC) and CCTV Camera** |  | 2017-07-19 | 2017-10-21 |  |  |  |  |  |  |  |  |  |  |  |  |
| CON-Z4-UTIL-COM-500 |  | Instalaltion of CCTV Fied Equipment Cabinet (FEC) | 36d | 2017-07-19 | 2017-08-30 | CON-Z4-UTIL-COM-490 | 0.4d | 0d |  | 133,364.45 | OK | 1.3.3.100 | CONS | CONS | ZONE-3 | COMM | COMM |
| CON-Z4-UTIL-COM-510 |  | Installation of Fixed Camera (95 No.) | 48d | 2017-08-06 | 2017-10-07 | CON-Z4-UTIL-COM-500 SS+15d | 0.4d | 0d |  | 444,548.16 | OK | 1.3.3.100 | CONS | CONS | ZONE-3 | COMM | COMM |
| CON-Z4-UTIL-COM-520 |  | Installation of Pole Camera (55 No.) | 30d | 2017-09-14 | 2017-10-21 | CON-Z4-UTIL-COM-510 SS+30d | 0.4d | 0d | Common Labor / Helper [1560 h]; Electrician [1560 h] | 311,183.71 | OK | 1.3.3.100 | CONS | CONS | ZONE-3 | COMM | COMM |
|  | 5 | **Internal Cabling System for CCTV** |  | 2017-09-20 | 2017-11-01 |  |  |  |  |  |  |  |  |  |  |  |  |
| CON-Z4-UTIL-COM-530 |  | Installation and Termination of Coaxial Cables from FEC to Camera | 20d | 2017-09-20 | 2017-10-15 | CON-Z4-UTIL-COM-520 SS+5d | 0.4d | 0d |  | 177,819.26 | OK | 1.3.3.100 | CONS | CONS | ZONE-3 | COMM | COMM |
| CON-Z4-UTIL-COM-540 |  | Instalaltion and Termination of Copper Control Cables for PTZ Camera | 18d | 2017-09-28 | 2017-10-19 | CON-Z4-UTIL-COM-530 SS+6d | 0.4d | 0d |  | 177,819.26 | OK | 1.3.3.100 | CONS | CONS | ZONE-3 | COMM | COMM |
| CON-Z4-UTIL-COM-550 |  | FOC Splicing | 29d | 2017-09-28 | 2017-11-01 | CON-Z4-UTIL-COM-540 SS, CON-Z4-UTIL-COM-530 SS | 0.4d | 0d |  | 118,546.17 | OK | 1.3.3.100 | CONS | CONS | ZONE-3 | COMM | COMM |
| CON-Z4-UTIL-COM-560 |  | Testing & Precommissioning of Communication & Security Systrems of Zone 3 | 19d | 2017-10-10 | 2017-11-01 | CON-Z4-UTIL-COM-550 SS+10d, CON-Z4-UTIL-COM-580 SS+18d | 0.4d | 0d |  | 118,546.17 | OK | 1.3.3.100 | CONS | CONS | ZONE-3 | COMM | COMM |

Notes:
- CON-Z4-UTIL-COM-400: Expenses: (New Expense Item) 59273.1
- CON-Z4-UTIL-COM-410: Expenses: (New Expense Item) 59273.1
- CON-Z4-UTIL-COM-420: Expenses: (New Expense Item) 177819
- CON-Z4-UTIL-COM-430: Expenses: (New Expense Item) 29636.5
- CON-Z4-UTIL-COM-440: Expenses: (New Expense Item) 118546
- CON-Z4-UTIL-COM-450: Expenses: (New Expense Item) 59273.1
- CON-Z4-UTIL-COM-580: Expenses: (New Expense Item) 88909.6
- CON-Z4-UTIL-COM-570: Expenses: (New Expense Item) 296365
- CON-Z4-UTIL-COM-460: Expenses: (New Expense Item) 118546
- CON-Z4-UTIL-COM-470: Expenses: (New Expense Item) 59273.1
- CON-Z4-UTIL-COM-480: Expenses: (New Expense Item) 237092
- CON-Z4-UTIL-COM-490: Expenses: (New Expense Item) 177819
- CON-Z4-UTIL-COM-500: Expenses: (New Expense Item) 133364
- CON-Z4-UTIL-COM-510: Expenses: (New Expense Item) 444548
- CON-Z4-UTIL-COM-520: Expenses: (New Expense Item) 311184
- CON-Z4-UTIL-COM-530: Expenses: (New Expense Item) 177819
- CON-Z4-UTIL-COM-540: Expenses: (New Expense Item) 177819
- CON-Z4-UTIL-COM-550: Expenses: (New Expense Item) 118546
- CON-Z4-UTIL-COM-560: Expenses: (New Expense Item) 118546

| ID | WBS | Activity | Duration | Start | Finish | Predecessors | Total float | Free float | Cost | Wajid | RPI_P2 - BOQ ITEMS | RPI_P2 - CONSTRUCTION | RPI_P2 - PHASE | RPI_P2 - ZONES | RPI_P2 - DISCIPLINE / WORK TYPE | RPI_P2 - BUILDINGS | RPI_P2 - UTILITY NETWORK |
| --- | --- | --- | --- | --- | --- | --- | --- | --- | --- | --- | --- | --- | --- | --- | --- | --- | --- |
|  | 2 | **SASC System** |  | 2017-06-10 | 2017-09-20 |  |  |  |  |  |  |  |  |  |  |  |  |
|  | 1 | **Research Park Exchange Building - SASC System** |  | 2017-06-10 | 2017-08-19 |  |  |  |  |  |  |  |  |  |  |  |  |
| CON-Z3-UTIL-COM-1690 |  | Installation of Conduits, Boxes & Fittings | 6d | 2017-06-10 | 2017-06-15 | CON-Z3-UTIL-COM-1610 SS+12d | 45d | 0d | 8,555.39 | OK | 1.3.3.100 | CONS | CONS | ZONE-3 | COMM | AEB | COMM |
| CON-Z3-UTIL-COM-1700 |  | Installation of Cameras, Card Readers, Exit Buttons & Accessories | 6d | 2017-06-17 | 2017-06-22 | CON-Z3-UTIL-COM-1690 | 69d | 0d | 8,555.39 | OK | 1.3.3.100 | CONS | CONS | ZONE-3 | COMM | AEB | COMM |
| CON-Z3-UTIL-COM-1710 |  | Installation of SASC Enclosures, Video Encoder & Equipments | 12d | 2017-06-24 | 2017-07-11 | CON-Z3-UTIL-COM-1700 | 69d | 0d | 8,555.39 | OK | 1.3.3.100 | CONS | CONS | ZONE-3 | COMM | AEB | COMM |
| CON-Z3-UTIL-COM-1720 |  | Pulling & Termination of Cables to Equipments | 18d | 2017-07-12 | 2017-08-01 | CON-Z3-UTIL-COM-1710 | 69d | 0d | 8,555.39 | OK | 1.3.3.100 | CONS | CONS | ZONE-3 | COMM | AEB | COMM |
| CON-Z3-UTIL-COM-1730 |  | Testing & Pre-commissioning for SASC System | 15d | 2017-08-02 | 2017-08-19 | CON-Z3-UTIL-COM-1720 | 69d | 50.4d | 8,555.39 | OK | 1.3.3.100 | CONS | CONS | ZONE-3 | COMM | AEB | COMM |
|  | 2 | **Sub-Station # 4 - SASC System** |  | 2017-06-24 | 2017-09-06 |  |  |  |  |  |  |  |  |  |  |  |  |
| CON-Z3-UTIL-COM-1740 |  | Installation of Conduits, Boxes & Fittings | 6d | 2017-06-24 | 2017-07-04 | CON-Z3-UTIL-COM-1690 SS+12d | 45d | 0d | 4,277.69 | OK | 1.3.3.100 | CONS | CONS | ZONE-3 | COMM | SS4 | COMM |
| CON-Z3-UTIL-COM-1750 |  | Installation of Cameras, Card Readers, Exit Buttons & Accessories | 6d | 2017-07-05 | 2017-07-11 | CON-Z3-UTIL-COM-1740 | 57d | 0d | 4,277.69 | OK | 1.3.3.100 | CONS | CONS | ZONE-3 | COMM | SS4 | COMM |
| CON-Z3-UTIL-COM-1760 |  | Installation of SASC Enclosures, Video Encoder & Equipments | 12d | 2017-07-12 | 2017-07-25 | CON-Z3-UTIL-COM-1750 | 57d | 0d | 4,277.69 | OK | 1.3.3.100 | CONS | CONS | ZONE-3 | COMM | SS4 | COMM |
| CON-Z3-UTIL-COM-1770 |  | Pulling & Termination of Cables to Equipments | 18d | 2017-07-26 | 2017-08-15 | CON-Z3-UTIL-COM-1760 | 57d | 0d | 4,277.69 | OK | 1.3.3.100 | CONS | CONS | ZONE-3 | COMM | SS4 | COMM |
| CON-Z3-UTIL-COM-1780 |  | Testing & Pre-commissioning for SASC System | 15d | 2017-08-16 | 2017-09-06 | CON-Z3-UTIL-COM-1770 | 57d | 38.4d | 4,277.69 | OK | 1.3.3.100 | CONS | CONS | ZONE-3 | COMM | SS4 | COMM |
|  | 3 | **Sub-Station # 5 - SASC System** |  | 2017-07-12 | 2017-09-20 |  |  |  |  |  |  |  |  |  |  |  |  |
| CON-Z3-UTIL-COM-1790 |  | Installation of Conduits, Boxes & Fittings | 6d | 2017-07-12 | 2017-07-18 | CON-Z3-UTIL-COM-1740 SS+12d | 45d | 0d | 4,277.69 | OK | 1.3.3.100 | CONS | CONS | ZONE-3 | COMM | SS5 | COMM |
| CON-Z3-UTIL-COM-1800 |  | Installation of Cameras, Card Readers, Exit Buttons & Accessories | 6d | 2017-07-19 | 2017-07-25 | CON-Z3-UTIL-COM-1790 | 45d | 0d | 4,277.69 | OK | 1.3.3.100 | CONS | CONS | ZONE-3 | COMM | SS5 | COMM |
| CON-Z3-UTIL-COM-1810 |  | Installation of SASC Enclosures, Video Encoder & Equipments | 12d | 2017-07-26 | 2017-08-08 | CON-Z3-UTIL-COM-1800 | 45d | 0d | 4,277.69 | OK | 1.3.3.100 | CONS | CONS | ZONE-3 | COMM | SS5 | COMM |
| CON-Z3-UTIL-COM-1820 |  | Pulling & Termination of Cables to Equipments | 18d | 2017-08-09 | 2017-08-29 | CON-Z3-UTIL-COM-1810 | 45d | 0d | 4,277.69 | OK | 1.3.3.100 | CONS | CONS | ZONE-3 | COMM | SS5 | COMM |
| CON-Z3-UTIL-COM-1830 |  | Testing & Pre-commissioning for SASC System | 15d | 2017-08-30 | 2017-09-20 | CON-Z3-UTIL-COM-1820 | 45d | 26.4d | 4,277.69 | OK | 1.3.3.100 | CONS | CONS | ZONE-3 | COMM | SS5 | COMM |
|  | 3 | **IP Phone System** |  | 2017-05-27 | 2017-10-05 |  |  |  |  |  |  |  |  |  |  |  |  |
|  | 1 | **Research Park Exchange Building - IP Phone System** |  | 2017-05-27 | 2017-08-09 |  |  |  |  |  |  |  |  |  |  |  |  |
| CON-Z3-UTIL-COM-1610 |  | Installation of IP Phones CISCO 7945G | 21d | 2017-05-27 | 2017-06-19 | PR-Z3-GE-GE-247-0090 FS+120d | 33.4d | 0d | 79,402.36 | OK | 1.3.3.100 | CONS | CONS | ZONE-3 | COMM | AEB | COMM |
| CON-Z3-UTIL-COM-1620 |  | Testing & Pre-commissioning of IP Phone System | 9.6d | 2017-07-30 | 2017-08-09 | CON-Z3-UTIL-COM-1610 FS+30d | 77.4d | 74.6d | 34,029.58 | OK | 1.3.3.100 | CONS | CONS | ZONE-3 | COMM | AEB | COMM |
|  | 2 | **Sub-Station # 5 - IP Phone System** |  | 2017-06-20 | 2017-08-19 |  |  |  |  |  |  |  |  |  |  |  |  |
| CON-Z3-UTIL-COM-1630 |  | Installation of IP Phones CISCO 7945G | 18d | 2017-06-20 | 2017-07-15 | CON-Z3-UTIL-COM-1610 | 33.4d | 0d | 39,701.18 | OK | 1.3.3.100 | CONS | CONS | ZONE-3 | COMM | SS5 | COMM |
| CON-Z3-UTIL-COM-1640 |  | Testing & Pre-commissioning of IP Phone System | 9.6d | 2017-08-08 | 2017-08-19 | CON-Z3-UTIL-COM-1630 FS+20d | 69.4d | 66.6d | 17,014.79 | OK | 1.3.3.100 | CONS | CONS | ZONE-3 | COMM | SS5 | COMM |

Notes:
- CON-Z3-UTIL-COM-1690: Expenses: (New Expense Item) 8555.39
- CON-Z3-UTIL-COM-1700: Expenses: (New Expense Item) 8555.39
- CON-Z3-UTIL-COM-1710: Expenses: (New Expense Item) 8555.39
- CON-Z3-UTIL-COM-1720: Expenses: (New Expense Item) 8555.39
- CON-Z3-UTIL-COM-1730: Expenses: (New Expense Item) 8555.39
- CON-Z3-UTIL-COM-1740: Expenses: (New Expense Item) 4277.69
- CON-Z3-UTIL-COM-1750: Expenses: (New Expense Item) 4277.69
- CON-Z3-UTIL-COM-1760: Expenses: (New Expense Item) 4277.69
- CON-Z3-UTIL-COM-1770: Expenses: (New Expense Item) 4277.69
- CON-Z3-UTIL-COM-1780: Expenses: (New Expense Item) 4277.69
- CON-Z3-UTIL-COM-1790: Expenses: (New Expense Item) 4277.69
- CON-Z3-UTIL-COM-1800: Expenses: (New Expense Item) 4277.69
- CON-Z3-UTIL-COM-1810: Expenses: (New Expense Item) 4277.69
- CON-Z3-UTIL-COM-1820: Expenses: (New Expense Item) 4277.69
- CON-Z3-UTIL-COM-1830: Expenses: (New Expense Item) 4277.69
- CON-Z3-UTIL-COM-1610: Expenses: (New Expense Item) 79402.4
- CON-Z3-UTIL-COM-1620: Expenses: (New Expense Item) 34029.6
- CON-Z3-UTIL-COM-1630: Expenses: (New Expense Item) 39701.2
- CON-Z3-UTIL-COM-1640: Expenses: (New Expense Item) 17014.8

| ID | WBS | Activity | Duration | Start | Finish | Predecessors | Total float | Free float | Cost | Wajid | RPI_P2 - BOQ ITEMS | RPI_P2 - CONSTRUCTION | RPI_P2 - PHASE | RPI_P2 - ZONES | RPI_P2 - DISCIPLINE / WORK TYPE | RPI_P2 - BUILDINGS | RPI_P2 - UTILITY NETWORK |
| --- | --- | --- | --- | --- | --- | --- | --- | --- | --- | --- | --- | --- | --- | --- | --- | --- | --- |
|  | 3 | **Sub-Station # 4 - IP Phone System** |  | 2017-07-16 | 2017-09-13 |  |  |  |  |  |  |  |  |  |  |  |  |
| CON-Z3-UTIL-COM-1650 |  | Installation of IP Phones CISCO 7945G | 18d | 2017-07-16 | 2017-08-05 | CON-Z3-UTIL-COM-1630 | 33.4d | 0d | 39,701.18 | OK | 1.3.3.100 | CONS | CONS | ZONE-3 | COMM | SS4 | COMM |
| CON-Z3-UTIL-COM-1660 |  | Testing & Pre-commissioning of IP Phone System | 9.6d | 2017-08-29 | 2017-09-13 | CON-Z3-UTIL-COM-1650 FS+20d | 51.4d | 48.6d | 17,014.79 | OK | 1.3.3.100 | CONS | CONS | ZONE-3 | COMM | SS4 | COMM |
|  | 4 | **Snack Booth 1 to 4 - IP Phone System** |  | 2017-08-06 | 2017-10-05 |  |  |  |  |  |  |  |  |  |  |  |  |
| CON-Z3-UTIL-COM-1670 |  | Installation of IP Phones CISCO 7945G | 18d | 2017-08-06 | 2017-08-26 | CON-Z3-UTIL-COM-1650 | 33.4d | 0d | 39,701.18 | OK | 1.3.3.100 | CONS | CONS | ZONE-3 | COMM | Snack-1 | COMM |
| CON-Z3-UTIL-COM-1680 |  | Testing & Pre-commissioning of IP Phone System | 9.6d | 2017-09-25 | 2017-10-05 | CON-Z3-UTIL-COM-1670 FS+20d | 33.4d | 30.6d | 17,014.79 | OK | 1.3.3.100 | CONS | CONS | ZONE-3 | COMM | Snack-1 | COMM |
|  | 4 | **Data Switches, Cabinets & Splicings** |  | 2017-05-10 | 2017-08-24 |  |  |  |  |  |  |  |  |  |  |  |  |
|  | 1 | **Snack Booth 1 & 3** |  | 2017-05-10 | 2017-08-07 |  |  |  |  |  |  |  |  |  |  |  |  |
| CON-Z3-UTIL-COM-1510 |  | Installation of Data Cabinet including Components | 6d | 2017-05-10 | 2017-05-17 | PR-Z3-CW-CS-77-0090 FS+60d | 34.6d | 0d | 26,582.94 | OK | 1.3.3.100 | CONS | CONS | ZONE-3 | COMM | Snack-1 | COMM |
| CON-Z3-UTIL-COM-1520 |  | Installation of Telecom Enclosure including Components | 6d | 2017-05-17 | 2017-05-24 | CON-Z3-UTIL-COM-1510, PR-Z3-CW-CS-78-0090 | 34.6d | 0d | 26,582.94 | OK | 1.3.3.100 | CONS | CONS | ZONE-3 | COMM | Snack-1 | COMM |
| CON-Z3-UTIL-COM-1530 |  | Installation of Conduits, Wiring Devices & Fittings | 12d | 2017-05-24 | 2017-06-07 | PR-Z3-CW-CS-79-0090, CON-Z3-UTIL-COM-1520 | 34.6d | 0d | 26,582.94 | OK | 1.3.3.100 | CONS | CONS | ZONE-3 | COMM | Snack-1 | COMM |
| CON-Z3-UTIL-COM-1540 |  | Pulling, Splicing & Termination of Cables to Equipments | 18d | 2017-06-07 | 2017-07-03 | CON-Z3-UTIL-COM-1530 | 49.6d | 0d | 26,582.94 | OK | 1.3.3.100 | CONS | CONS | ZONE-3 | COMM | Snack-1 | COMM |
| CON-Z3-UTIL-COM-1550 |  | Testing & Pre-Commissioning of FOC & Equipments | 15d | 2017-07-20 | 2017-08-07 | CON-Z3-UTIL-COM-1540 FS+15d | 49.6d | 31d | 26,582.94 | OK | 1.3.3.100 | CONS | CONS | ZONE-3 | COMM | Snack-1 | COMM |
|  | 2 | **Snack Booth 2 & 4** |  | 2017-06-14 | 2017-08-24 |  |  |  |  |  |  |  |  |  |  |  |  |
| CON-Z3-UTIL-COM-1560 |  | Installation of Data Cabinet including Components | 6d | 2017-06-14 | 2017-06-21 | CON-Z3-UTIL-COM-1530 FS+6d, CON-Z3-UTIL-COM-1510 FS+12d | 34.6d | 0d | 26,582.94 | OK | 1.3.3.100 | CONS | CONS | ZONE-3 | COMM | Snack-1 | COMM |
| CON-Z3-UTIL-COM-1570 |  | Installation of Telecom Enclosure including Components | 6d | 2017-06-21 | 2017-07-03 | CON-Z3-UTIL-COM-1560, CON-Z3-UTIL-COM-1520 | 34.6d | 0d | 26,582.94 | OK | 1.3.3.100 | CONS | CONS | ZONE-3 | COMM | Snack-1 | COMM |
| CON-Z3-UTIL-COM-1580 |  | Installation of Conduits, Wiring Devices & Fittings | 12d | 2017-07-03 | 2017-07-17 | CON-Z3-UTIL-COM-1570 | 34.6d | 0d | 26,582.94 | OK | 1.3.3.100 | CONS | CONS | ZONE-3 | COMM | Snack-1 | COMM |
| CON-Z3-UTIL-COM-1590 |  | Pulling, Splicing & Termination of Cables to Equipments | 18d | 2017-07-17 | 2017-08-07 | CON-Z3-UTIL-COM-1580 | 34.6d | 0d | 26,582.94 | OK | 1.3.3.100 | CONS | CONS | ZONE-3 | COMM | Snack-1 | COMM |
| CON-Z3-UTIL-COM-1600 |  | Testing & Pre-Commissioning of FOC & Equipments | 15d | 2017-08-07 | 2017-08-24 | CON-Z3-UTIL-COM-1590 | 34.6d | 16d | 26,582.94 | OK | 1.3.3.100 | CONS | CONS | ZONE-3 | COMM | Snack-1 | COMM |
|  | 5 | **Remaining Communication Works** |  | 2017-05-02 | 2017-10-14 |  |  |  |  |  |  |  |  |  |  |  |  |
|  | 1 | **Research Exchange Building - Remaining Communication Works** |  | 2017-05-08 | 2017-10-14 |  |  |  |  |  |  |  |  |  |  |  |  |
| CON-Z3-UTIL-COM-0310 |  | Installation of Splice Closures | 12d | 2017-05-08 | 2017-05-21 | PR-Z3-CW-CS-81-0090 FS+60d | 41d | 0d | 197,139.09 | OK | 1.3.3.100 | CONS | CONS | ZONE-3 | COMM | AEB | COMM |
| CON-Z3-UTIL-COM-0320 |  | Installation of ADTRAN 850 | 12d | 2017-05-22 | 2017-06-04 | CON-Z3-UTIL-COM-0310, PR-Z3-CW-CS-82-0090 | 41d | 0d | 131,426.06 | OK | 1.3.3.100 | CONS | CONS | ZONE-3 | COMM | AEB | COMM |
| CON-Z3-UTIL-COM-0330 |  | Installation of TYPE "L" DOUBLE SIDED MDF 9' X 10 VERTICAL | 12d | 2017-06-05 | 2017-06-18 | CON-Z3-UTIL-COM-0320, PR-Z3-CW-CS-82-0190 | 41d | 0d | 131,426.06 | OK | 1.3.3.100 | CONS | CONS | ZONE-3 | COMM | AEB | COMM |
| CON-Z3-UTIL-COM-0340 |  | Installation of Fiber Optic Patch Panels | 12d | 2017-06-19 | 2017-07-06 | CON-Z3-UTIL-COM-0330 | 41d | 0d | 262,852.12 | OK | 1.3.3.100 | CONS | CONS | ZONE-3 | COMM | AEB | COMM |
| CON-Z3-UTIL-COM-0350 |  | Pulling of Fiber Optic & Copper Cables including Conduits & fittings | 36d | 2017-06-19 | 2017-08-03 | PR-Z3-CW-FO-68-0090, CON-Z3-UTIL-COM-0330, CON-Z3-UTIL-COM-0340 SS, PR-Z3-CW-FO-66-0090, CON-Z3-UTIL-COM-0320, CON-Z3-UTIL-COM-0310, PR-Z3-CW-CS-71-0090, PR-Z3-CW-CS-70-0090 | 41d | 0d | 262,852.12 | OK | 1.3.3.100 | CONS | CONS | ZONE-3 | COMM | AEB | COMM |
| CON-Z3-UTIL-COM-0360 |  | Splicing & Termination of Fiber Optic & Copper Cables to equipments | 30d | 2017-08-05 | 2017-09-12 | PR-Z3-CW-FO-67-0080, CON-Z3-UTIL-COM-0350, PR-Z3-CW-CS-72-0090, PR-Z3-CW-FO-69-0090 | 41d | 0d | 131,426.06 | OK | 1.3.3.100 | CONS | CONS | ZONE-3 | COMM | AEB | COMM |
| CON-Z3-UTIL-COM-0370 |  | Testing & Pre-Commissioning of FOC & Communication Equipments | 26d | 2017-09-13 | 2017-10-14 | CON-Z3-UTIL-COM-0360, CON-Z3-UTIL-COM-1150, CON-Z3-UTIL-COM-0460 | 41d | 38.2d | 197,139.09 | OK | 1.3.3.100 | CONS | CONS | ZONE-3 | COMM | AEB | COMM |

Notes:
- CON-Z3-UTIL-COM-1650: Expenses: (New Expense Item) 39701.2
- CON-Z3-UTIL-COM-1660: Expenses: (New Expense Item) 17014.8
- CON-Z3-UTIL-COM-1670: Expenses: (New Expense Item) 39701.2
- CON-Z3-UTIL-COM-1680: Expenses: (New Expense Item) 17014.8
- CON-Z3-UTIL-COM-1510: Expenses: (New Expense Item) 26582.9
- CON-Z3-UTIL-COM-1520: Expenses: (New Expense Item) 26582.9
- CON-Z3-UTIL-COM-1530: Expenses: (New Expense Item) 26582.9
- CON-Z3-UTIL-COM-1540: Expenses: (New Expense Item) 26582.9
- CON-Z3-UTIL-COM-1550: Expenses: (New Expense Item) 26582.9
- CON-Z3-UTIL-COM-1560: Expenses: (New Expense Item) 26582.9
- CON-Z3-UTIL-COM-1570: Expenses: (New Expense Item) 26582.9
- CON-Z3-UTIL-COM-1580: Expenses: (New Expense Item) 26582.9
- CON-Z3-UTIL-COM-1590: Expenses: (New Expense Item) 26582.9
- CON-Z3-UTIL-COM-1600: Expenses: (New Expense Item) 26582.9
- CON-Z3-UTIL-COM-0310: Expenses: (New Expense Item) 197139
- CON-Z3-UTIL-COM-0320: Expenses: (New Expense Item) 131426
- CON-Z3-UTIL-COM-0330: Expenses: (New Expense Item) 131426
- CON-Z3-UTIL-COM-0340: Expenses: (New Expense Item) 262852
- CON-Z3-UTIL-COM-0350: Expenses: (New Expense Item) 262852
- CON-Z3-UTIL-COM-0360: Expenses: (New Expense Item) 131426
- CON-Z3-UTIL-COM-0370: Expenses: (New Expense Item) 197139

| ID | WBS | Activity | Duration | Start | Finish | Predecessors | Total float | Free float | Cost | Wajid | RPI_P2 - BOQ ITEMS | RPI_P2 - CONSTRUCTION | RPI_P2 - PHASE | RPI_P2 - ZONES | RPI_P2 - DISCIPLINE / WORK TYPE | RPI_P2 - BUILDINGS | RPI_P2 - UTILITY NETWORK |
| --- | --- | --- | --- | --- | --- | --- | --- | --- | --- | --- | --- | --- | --- | --- | --- | --- | --- |
|  | 2 | **Sub-Station # 4 - Interface to Fire Alarm** |  | 2017-05-02 | 2017-07-18 |  |  |  |  |  |  |  |  |  |  |  |  |
| CON-Z3-UTIL-COM-0410 |  | Installation of Splice Closures | 12d | 2017-05-02 | 2017-05-15 | PR-Z3-CW-CS-83-0090 FS+55d | 47.2d | 0d | 98,569.54 | OK | 1.3.3.100 | CONS | CONS | ZONE-3 | COMM | SS4 | COMM |
| CON-Z3-UTIL-COM-0420 |  | Installation of Patch Panels | 12d | 2017-05-16 | 2017-05-29 | CON-Z3-UTIL-COM-0410 | 47.2d | 0d | 164,282.57 | OK | 1.3.3.100 | CONS | CONS | ZONE-3 | COMM | SS4 | COMM |
| CON-Z3-UTIL-COM-0430 |  | Installation of Conduits & Fittings | 4.8d | 2017-05-30 | 2017-06-04 | CON-Z3-UTIL-COM-0420 | 47.2d | 0d | 65,713.03 | OK | 1.3.3.100 | CONS | CONS | ZONE-3 | COMM | SS4 | COMM |
| CON-Z3-UTIL-COM-0440 |  | Pulling of Fiber Optic & Copper Cables | 9.6d | 2017-06-04 | 2017-06-15 | CON-Z3-UTIL-COM-0430 | 47.2d | 0d | 131,426.06 | OK | 1.3.3.100 | CONS | CONS | ZONE-3 | COMM | SS4 | COMM |
| CON-Z3-UTIL-COM-0450 |  | Splicing & Termination of Fiber Optic & Copper Cables to equipments | 14.4d | 2017-06-15 | 2017-07-06 | CON-Z3-UTIL-COM-0440 | 85.6d | 0d | 65,713.03 | OK | 1.3.3.100 | CONS | CONS | ZONE-3 | COMM | SS4 | COMM |
| CON-Z3-UTIL-COM-0460 |  | Testing & Pre-Commissioning of FOC & Communication Equipments | 9.6d | 2017-07-06 | 2017-07-18 | CON-Z3-UTIL-COM-0450 | 85.6d | 44.6d | 131,426.06 | OK | 1.3.3.100 | CONS | CONS | ZONE-3 | COMM | SS4 | COMM |
|  | 3 | **Sub-Station # 5 - Interface to Fire Alarm** |  | 2017-06-15 | 2017-09-05 |  |  |  |  |  |  |  |  |  |  |  |  |
| CON-Z3-UTIL-COM-1100 |  | Installation of Splice Closures | 12d | 2017-06-15 | 2017-07-04 | CON-Z3-UTIL-COM-0440, PR-Z3-CW-CS-83-0090 | 47.2d | 0d | 98,569.54 | OK | 1.3.3.100 | CONS | CONS | ZONE-3 | COMM | SS5 | COMM |
| CON-Z3-UTIL-COM-1110 |  | Installation of Patch Panels | 12d | 2017-07-04 | 2017-07-18 | CON-Z3-UTIL-COM-1100 | 47.2d | 0d | 164,282.57 | OK | 1.3.3.100 | CONS | CONS | ZONE-3 | COMM | SS5 | COMM |
| CON-Z3-UTIL-COM-1120 |  | Installation of Conduits & Fittings | 4.8d | 2017-07-18 | 2017-07-24 | CON-Z3-UTIL-COM-1110 | 47.2d | 0d | 65,713.03 | OK | 1.3.3.100 | CONS | CONS | ZONE-3 | COMM | SS5 | COMM |
| CON-Z3-UTIL-COM-1130 |  | Pulling of Fiber Optic & Copper Cables | 9.6d | 2017-07-24 | 2017-08-03 | CON-Z3-UTIL-COM-1120 | 47.2d | 0d | 131,426.06 | OK | 1.3.3.100 | CONS | CONS | ZONE-3 | COMM | SS5 | COMM |
| CON-Z3-UTIL-COM-1140 |  | Splicing & Termination of Fiber Optic & Copper Cables to equipments | 14.4d | 2017-08-03 | 2017-08-21 | CON-Z3-UTIL-COM-1130 | 47.2d | 0d | 65,713.03 | OK | 1.3.3.100 | CONS | CONS | ZONE-3 | COMM | SS5 | COMM |
| CON-Z3-UTIL-COM-1150 |  | Testing & Pre-Commissioning of FOC & Communication Equipments | 9.6d | 2017-08-21 | 2017-09-05 | CON-Z3-UTIL-COM-1140 | 47.2d | 6.2d | 131,426.06 | OK | 1.3.3.100 | CONS | CONS | ZONE-3 | COMM | SS5 | COMM |
|  | 3 | **Communication Manholes, Duct Banks & Conduits System** |  | 2016-12-25 | 2017-07-09 |  |  |  |  |  |  |  |  |  |  |  |  |
|  | 1 | **Remaining Works - Comm. Manhole T-001 MH-1025 TYPE-2A** |  | 2016-12-25 | 2017-02-02 |  |  |  |  |  |  |  |  |  |  |  |  |
| CON-Z3-UTIL-COM-0500 |  | Manhole Cleaning & Grounding Works | 6d | 2016-12-25 | 2017-01-01 | PR-Z3-CW-CS-88-0090 SS | 115.2d | 0d | 36,714.84 | OK | 1.3.3.100 | CONS | CONS | ZONE-3 | COMM |  | COMM |
| CON-Z3-UTIL-COM-0510 |  | Manhole Frame & Covers | 4d | 2017-01-25 | 2017-01-30 | CON-Z3-UTIL-COM-0500, PR-Z3-CW-CS-89-0090 | 94.2d | 0d | 22,028.9 | OK | 1.3.3.100 | CONS | CONS | ZONE-3 | COMM |  | COMM |
| CON-Z3-UTIL-COM-0520 |  | Backfilling | 3d | 2017-01-30 | 2017-02-02 | CON-Z3-UTIL-COM-0510 | 94.2d | 0d | 14,685.94 | OK | 1.3.3.100 | CONS | CONS | ZONE-3 | COMM |  | COMM |
|  | 2 | **Remaining Works - Comm. Manhole T-002 MH-1005 TYPE-1b** |  | 2016-12-25 | 2017-02-02 |  |  |  |  |  |  |  |  |  |  |  |  |
| CON-Z3-UTIL-COM-0530 |  | Manhole Cleaning & Grounding Works | 6d | 2016-12-25 | 2017-01-01 | CON-Z3-UTIL-COM-0500 SS | 115.2d | 0d | 36,714.84 | OK | 1.3.3.100 | CONS | CONS | ZONE-3 | COMM |  | COMM |
| CON-Z3-UTIL-COM-0540 |  | Manhole Frame & Covers | 4d | 2017-01-01 | 2017-01-05 | CON-Z3-UTIL-COM-0530 | 115.2d | 21d | 22,028.9 | OK | 1.3.3.100 | CONS | CONS | ZONE-3 | COMM |  | COMM |
| CON-Z3-UTIL-COM-0550 |  | Backfilling | 3d | 2017-01-30 | 2017-02-02 | CON-Z3-UTIL-COM-0520 SS, CON-Z3-UTIL-COM-0540 | 94.2d | 0d | 14,685.94 | OK | 1.3.3.100 | CONS | CONS | ZONE-3 | COMM |  | COMM |
|  | 3 | **Remaining Works - Comm. Manhole T-003 MH-1024 TYPE-1b** |  | 2017-01-30 | 2017-02-04 |  |  |  |  |  |  |  |  |  |  |  |  |
| CON-Z3-UTIL-COM-0560 |  | Manhole Cleaning & Grounding Works | 4d | 2017-01-30 | 2017-02-04 | CON-Z3-UTIL-COM-0550 SS, CON-Z3-UTIL-COM-0530, CON-Z3-UTIL-COM-0530 FF | 94.2d | 0d | 73,429.68 | OK | 1.3.3.100 | CONS | CONS | ZONE-3 | COMM |  | COMM |

Notes:
- CON-Z3-UTIL-COM-0410: Expenses: (New Expense Item) 98569.5
- CON-Z3-UTIL-COM-0420: Expenses: (New Expense Item) 164283
- CON-Z3-UTIL-COM-0430: Expenses: (New Expense Item) 65713
- CON-Z3-UTIL-COM-0440: Expenses: (New Expense Item) 131426
- CON-Z3-UTIL-COM-0450: Expenses: (New Expense Item) 65713
- CON-Z3-UTIL-COM-0460: Expenses: (New Expense Item) 131426
- CON-Z3-UTIL-COM-1100: Expenses: (New Expense Item) 98569.5
- CON-Z3-UTIL-COM-1110: Expenses: (New Expense Item) 164283
- CON-Z3-UTIL-COM-1120: Expenses: (New Expense Item) 65713
- CON-Z3-UTIL-COM-1130: Expenses: (New Expense Item) 131426
- CON-Z3-UTIL-COM-1140: Expenses: (New Expense Item) 65713
- CON-Z3-UTIL-COM-1150: Expenses: (New Expense Item) 131426
- CON-Z3-UTIL-COM-0500: Expenses: (New Expense Item) 36714.8
- CON-Z3-UTIL-COM-0510: Expenses: (New Expense Item) 22028.9
- CON-Z3-UTIL-COM-0520: Expenses: (New Expense Item) 14685.9
- CON-Z3-UTIL-COM-0530: Expenses: (New Expense Item) 36714.8
- CON-Z3-UTIL-COM-0540: Expenses: (New Expense Item) 22028.9
- CON-Z3-UTIL-COM-0550: Expenses: (New Expense Item) 14685.9
- CON-Z3-UTIL-COM-0560: Expenses: (New Expense Item) 73429.7

| ID | WBS | Activity | Duration | Start | Finish | Predecessors | Total float | Free float | Cost | Wajid | RPI_P2 - BOQ ITEMS | RPI_P2 - CONSTRUCTION | RPI_P2 - PHASE | RPI_P2 - ZONES | RPI_P2 - DISCIPLINE / WORK TYPE | RPI_P2 - UTILITY NETWORK |
| --- | --- | --- | --- | --- | --- | --- | --- | --- | --- | --- | --- | --- | --- | --- | --- | --- |
|  | 4 | **Remaining Works - Comm. Manhole T-004 MH-1015 TYPE-1b & Duct Bank Backfilling** |  | 2017-02-04 | 2017-02-14 |  |  |  |  |  |  |  |  |  |  |  |
| CON-Z3-UTIL-COM-0570 |  | Manhole Cleaning & Grounding Works | 5d | 2017-02-04 | 2017-02-09 | CON-Z3-UTIL-COM-0560 | 94.2d | 0d | 45,893.55 | OK | 1.3.3.100 | CONS | CONS | ZONE-3 | COMM | COMM |
| CON-Z3-UTIL-COM-0580 |  | Warning Tape & Duct Bank Backfilling | 4d | 2017-02-09 | 2017-02-14 | PR-Z3-CW-CS-90-0090, CON-Z3-UTIL-COM-0570 | 94.2d | 0d | 45,893.55 | OK | 1.3.3.100 | CONS | CONS | ZONE-3 | COMM | COMM |
|  | 5 | **Remaining Works - Comm. Manhole T-005** |  | 2017-02-09 | 2017-02-21 |  |  |  |  |  |  |  |  |  |  |  |
| CON-Z3-UTIL-COM-0590 |  | Manhole Cleaning & Grounding Works | 4d | 2017-02-09 | 2017-02-14 | CON-Z3-UTIL-COM-0580 SS, CON-Z3-UTIL-COM-0570 | 94.2d | 0d | 36,714.84 | OK | 1.3.3.100 | CONS | CONS | ZONE-3 | COMM | COMM |
| CON-Z3-UTIL-COM-0600 |  | Manhole Frame & Covers | 4d | 2017-02-14 | 2017-02-19 | CON-Z3-UTIL-COM-0590 | 188.2d | 0d | 22,028.9 | OK | 1.3.3.100 | CONS | CONS | ZONE-3 | COMM | COMM |
| CON-Z3-UTIL-COM-0610 |  | Backfilling | 2d | 2017-02-19 | 2017-02-21 | CON-Z3-UTIL-COM-0600 | 188.2d | 8d | 14,685.94 | OK | 1.3.3.100 | CONS | CONS | ZONE-3 | COMM | COMM |
|  | 6 | **Remaining Works - Comm. Manhole T-006 & Duct Bank Backfilling** |  | 2017-02-14 | 2017-02-23 |  |  |  |  |  |  |  |  |  |  |  |
| CON-Z3-UTIL-COM-0620 |  | Manhole Cleaning & Grounding Works | 4d | 2017-02-14 | 2017-02-19 | CON-Z3-UTIL-COM-0590 | 94.2d | 0d | 45,893.55 | OK | 1.3.3.100 | CONS | CONS | ZONE-3 | COMM | COMM |
| CON-Z3-UTIL-COM-0630 |  | Warning Tape & Duct Bank Backfilling | 4d | 2017-02-19 | 2017-02-23 | CON-Z3-UTIL-COM-0580 SS, CON-Z3-UTIL-COM-0620 | 94.2d | 0d | 45,893.55 | OK | 1.3.3.100 | CONS | CONS | ZONE-3 | COMM | COMM |
|  | 7 | **Remaining Works - Comm. Manhole T-007 MH-1002 TYPE-2a** |  | 2017-02-19 | 2017-03-02 |  |  |  |  |  |  |  |  |  |  |  |
| CON-Z3-UTIL-COM-0640 |  | Manhole Cleaning & Grounding Works | 4d | 2017-02-19 | 2017-02-23 | CON-Z3-UTIL-COM-0620 SS, CON-Z3-UTIL-COM-0620 FF, CON-Z3-UTIL-COM-0630 SS, CON-Z3-UTIL-COM-0620 | 94.2d | 0d | 36,714.84 | OK | 1.3.3.100 | CONS | CONS | ZONE-3 | COMM | COMM |
| CON-Z3-UTIL-COM-0650 |  | Manhole Frame & Covers | 4d | 2017-02-23 | 2017-02-28 | CON-Z3-UTIL-COM-0640 | 180.2d | 0d | 22,028.9 | OK | 1.3.3.100 | CONS | CONS | ZONE-3 | COMM | COMM |
| CON-Z3-UTIL-COM-0660 |  | Backfilling | 2d | 2017-02-28 | 2017-03-02 | CON-Z3-UTIL-COM-0610 SS, CON-Z3-UTIL-COM-0650 | 180.2d | 12d | 14,685.94 | OK | 1.3.3.100 | CONS | CONS | ZONE-3 | COMM | COMM |
|  | 8 | **Remaining Works - Comm. Manhole T-008 MH-1023 TYPE-1b** |  | 2017-02-23 | 2017-02-28 |  |  |  |  |  |  |  |  |  |  |  |
| CON-Z3-UTIL-COM-0670 |  | Manhole Cleaning & Grounding Works | 4d | 2017-02-23 | 2017-02-28 | CON-Z3-UTIL-COM-0640, CON-Z3-UTIL-COM-0640 FF | 94.2d | 0d | 73,429.68 | OK | 1.3.3.100 | CONS | CONS | ZONE-3 | COMM | COMM |
|  | 9 | **Remaining Works - Comm. Manhole T-009 MH-1023 TYPE-1b** |  | 2017-02-28 | 2017-03-05 |  |  |  |  |  |  |  |  |  |  |  |
| CON-Z3-UTIL-COM-0680 |  | Manhole Cleaning & Grounding Works | 4d | 2017-02-28 | 2017-03-05 | CON-Z3-UTIL-COM-0670 | 94.2d | 0d | 73,429.68 | OK | 1.3.3.100 | CONS | CONS | ZONE-3 | COMM | COMM |
|  | 10 | **Remaining Works - Comm. Manhole T-010 MH-1001 TYPE-2a** |  | 2017-03-05 | 2017-03-16 |  |  |  |  |  |  |  |  |  |  |  |
| CON-Z3-UTIL-COM-0690 |  | Manhole Cleaning & Grounding Works | 4d | 2017-03-05 | 2017-03-09 | CON-Z3-UTIL-COM-0680 | 94.2d | 0d | 36,714.84 | OK | 1.3.3.100 | CONS | CONS | ZONE-3 | COMM | COMM |
| CON-Z3-UTIL-COM-0700 |  | Manhole Frame & Covers | 4d | 2017-03-09 | 2017-03-14 | CON-Z3-UTIL-COM-0690 | 168.2d | 0d | 22,028.9 | OK | 1.3.3.100 | CONS | CONS | ZONE-3 | COMM | COMM |
| CON-Z3-UTIL-COM-0710 |  | Backfilling | 2d | 2017-03-14 | 2017-03-16 | CON-Z3-UTIL-COM-0700, CON-Z3-UTIL-COM-0660 SS | 168.2d | 12d | 14,685.94 | OK | 1.3.3.100 | CONS | CONS | ZONE-3 | COMM | COMM |
|  | 11 | **Remaining Works - Comm. Manhole T-011 & Duct Bank Backfilling** |  | 2017-03-09 | 2017-03-18 |  |  |  |  |  |  |  |  |  |  |  |
| CON-Z3-UTIL-COM-0720 |  | Manhole Cleaning & Grounding Works | 4d | 2017-03-09 | 2017-03-14 | CON-Z3-UTIL-COM-0690 | 94.2d | 0d | 45,893.55 | OK | 1.3.3.100 | CONS | CONS | ZONE-3 | COMM | COMM |
| CON-Z3-UTIL-COM-0730 |  | Warning Tape & Duct Bank Backfilling | 3d | 2017-03-14 | 2017-03-18 | CON-Z3-UTIL-COM-0720 | 106.2d | 4d | 45,893.55 | OK | 1.3.3.100 | CONS | CONS | ZONE-3 | COMM | COMM |

Notes:
- CON-Z3-UTIL-COM-0570: Expenses: (New Expense Item) 45893.6
- CON-Z3-UTIL-COM-0580: Expenses: (New Expense Item) 45893.6
- CON-Z3-UTIL-COM-0590: Expenses: (New Expense Item) 36714.8
- CON-Z3-UTIL-COM-0600: Expenses: (New Expense Item) 22028.9
- CON-Z3-UTIL-COM-0610: Expenses: (New Expense Item) 14685.9
- CON-Z3-UTIL-COM-0620: Expenses: (New Expense Item) 45893.6
- CON-Z3-UTIL-COM-0630: Expenses: (New Expense Item) 45893.6
- CON-Z3-UTIL-COM-0640: Expenses: (New Expense Item) 36714.8
- CON-Z3-UTIL-COM-0650: Expenses: (New Expense Item) 22028.9
- CON-Z3-UTIL-COM-0660: Expenses: (New Expense Item) 14685.9
- CON-Z3-UTIL-COM-0670: Expenses: (New Expense Item) 73429.7
- CON-Z3-UTIL-COM-0680: Expenses: (New Expense Item) 73429.7
- CON-Z3-UTIL-COM-0690: Expenses: (New Expense Item) 36714.8
- CON-Z3-UTIL-COM-0700: Expenses: (New Expense Item) 22028.9
- CON-Z3-UTIL-COM-0710: Expenses: (New Expense Item) 14685.9
- CON-Z3-UTIL-COM-0720: Expenses: (New Expense Item) 45893.6
- CON-Z3-UTIL-COM-0730: Expenses: (New Expense Item) 45893.6

| ID | WBS | Activity | Duration | Start | Finish | Predecessors | Total float | Free float | Cost | Wajid | RPI_P2 - BOQ ITEMS | RPI_P2 - CONSTRUCTION | RPI_P2 - PHASE | RPI_P2 - ZONES | RPI_P2 - DISCIPLINE / WORK TYPE | RPI_P2 - UTILITY NETWORK |
| --- | --- | --- | --- | --- | --- | --- | --- | --- | --- | --- | --- | --- | --- | --- | --- | --- |
|  | 12 | **Remaining Works - Comm. Manhole T-012 & Duct Bank Backfilling** |  | 2017-03-14 | 2017-03-22 |  |  |  |  |  |  |  |  |  |  |  |
| CON-Z3-UTIL-COM-0740 |  | Manhole Cleaning & Grounding Works | 4d | 2017-03-14 | 2017-03-19 | CON-Z3-UTIL-COM-0720 | 94.2d | 0d | 45,893.55 | OK | 1.3.3.100 | CONS | CONS | ZONE-3 | COMM | COMM |
| CON-Z3-UTIL-COM-0750 |  | Warning Tape & Duct Bank Backfilling | 3d | 2017-03-19 | 2017-03-22 | CON-Z3-UTIL-COM-0730 SS, CON-Z3-UTIL-COM-0740 | 102.2d | 8d | 45,893.55 | OK | 1.3.3.100 | CONS | CONS | ZONE-3 | COMM | COMM |
|  | 13 | **Remaining Works - Comm. Manhole T-013 MH-34 TYPE-2a** |  | 2017-03-19 | 2017-03-30 |  |  |  |  |  |  |  |  |  |  |  |
| CON-Z3-UTIL-COM-0760 |  | Manhole Cleaning & Grounding Works | 4d | 2017-03-19 | 2017-03-23 | CON-Z3-UTIL-COM-0740 | 94.2d | 0d | 36,714.84 | OK | 1.3.3.100 | CONS | CONS | ZONE-3 | COMM | COMM |
| CON-Z3-UTIL-COM-0770 |  | Manhole Frame & Covers | 4d | 2017-03-23 | 2017-03-28 | CON-Z3-UTIL-COM-0760 | 156.2d | 0d | 22,028.9 | OK | 1.3.3.100 | CONS | CONS | ZONE-3 | COMM | COMM |
| CON-Z3-UTIL-COM-0780 |  | Backfilling | 2d | 2017-03-28 | 2017-03-30 | CON-Z3-UTIL-COM-0710 SS, CON-Z3-UTIL-COM-0770 | 156.2d | 8d | 14,685.94 | OK | 1.3.3.100 | CONS | CONS | ZONE-3 | COMM | COMM |
|  | 14 | **Remaining Works - Comm. Manhole T-014 MH-1023 TYPE-1b** |  | 2017-03-23 | 2017-04-01 |  |  |  |  |  |  |  |  |  |  |  |
| CON-Z3-UTIL-COM-0790 |  | Manhole Cleaning & Grounding Works | 4d | 2017-03-23 | 2017-03-28 | CON-Z3-UTIL-COM-0760 | 94.2d | 0d | 36,714.84 | OK | 1.3.3.100 | CONS | CONS | ZONE-3 | COMM | COMM |
| CON-Z3-UTIL-COM-0800 |  | Warning Tape & Duct Bank Backfilling | 3d | 2017-03-28 | 2017-04-01 | CON-Z3-UTIL-COM-0790, CON-Z3-UTIL-COM-0750 SS | 94.2d | 0d | 36,714.84 | OK | 1.3.3.100 | CONS | CONS | ZONE-3 | COMM | COMM |
|  | 15 | **Remaining Works - Comm. Manhole T-128 MH-35 TYPE-2a** |  | 2017-03-28 | 2017-04-09 |  |  |  |  |  |  |  |  |  |  |  |
| CON-Z3-UTIL-COM-0810 |  | Manhole Cleaning & Grounding Works | 4d | 2017-03-28 | 2017-04-02 | CON-Z3-UTIL-COM-0800 SS, CON-Z3-UTIL-COM-0790 | 94.2d | 0d | 36,714.84 | OK | 1.3.3.100 | CONS | CONS | ZONE-3 | COMM | COMM |
| CON-Z3-UTIL-COM-0820 |  | Manhole Frame & Covers | 4d | 2017-04-02 | 2017-04-06 | CON-Z3-UTIL-COM-0810 | 148.2d | 0d | 22,028.9 | OK | 1.3.3.100 | CONS | CONS | ZONE-3 | COMM | COMM |
| CON-Z3-UTIL-COM-0830 |  | Backfilling | 2d | 2017-04-06 | 2017-04-09 | CON-Z3-UTIL-COM-0780 SS, CON-Z3-UTIL-COM-0820 | 148.2d | 34d | 14,685.94 | OK | 1.3.3.100 | CONS | CONS | ZONE-3 | COMM | COMM |
|  | 16 | **Remaining Works - Comm. Manhole T-104 MH-1018 TYPE-1b** |  | 2017-05-07 | 2017-05-18 |  |  |  |  |  |  |  |  |  |  |  |
| CON-Z3-UTIL-COM-0840 |  | Manhole Cleaning & Grounding Works | 4d | 2017-05-07 | 2017-05-11 | CON-Z3-UTIL-COM-0810 FS+30d | 94.2d | 0d | 36,714.84 | OK | 1.3.3.100 | CONS | CONS | ZONE-3 | COMM | COMM |
| CON-Z3-UTIL-COM-0850 |  | Manhole Frame & Covers | 4d | 2017-05-11 | 2017-05-16 | CON-Z3-UTIL-COM-0840 | 114.2d | 0d | 22,028.9 | OK | 1.3.3.100 | CONS | CONS | ZONE-3 | COMM | COMM |
| CON-Z3-UTIL-COM-0860 |  | Backfilling | 2d | 2017-05-16 | 2017-05-18 | CON-Z3-UTIL-COM-0830 SS, CON-Z3-UTIL-COM-0850 | 114.2d | 11d | 14,685.94 | OK | 1.3.3.100 | CONS | CONS | ZONE-3 | COMM | COMM |
|  | 17 | **Remaining Works - Comm. Manhole T-106 & Duct Bank Backfilling** |  | 2017-05-11 | 2017-05-20 |  |  |  |  |  |  |  |  |  |  |  |
| CON-Z3-UTIL-COM-0870 |  | Manhole Cleaning & Grounding Works | 4d | 2017-05-11 | 2017-05-16 | CON-Z3-UTIL-COM-0840 | 94.2d | 0d | 36,714.84 | OK | 1.3.3.100 | CONS | CONS | ZONE-3 | COMM | COMM |
| CON-Z3-UTIL-COM-0880 |  | Warning Tape & Duct Bank Backfilling | 3d | 2017-05-16 | 2017-05-20 | CON-Z3-UTIL-COM-0870 | 94.2d | 0d | 36,714.84 | OK | 1.3.3.100 | CONS | CONS | ZONE-3 | COMM | COMM |
|  | 18 | **Remaining Works - Comm. Manhole T-107 Duct Bank Backfilling & MH-1019 & 1020 TYPE-1b** |  | 2017-05-16 | 2017-06-01 |  |  |  |  |  |  |  |  |  |  |  |
| CON-Z3-UTIL-COM-0890 |  | Manhole Cleaning & Grounding Works | 4d | 2017-05-16 | 2017-05-21 | CON-Z3-UTIL-COM-0870, CON-Z3-UTIL-COM-0880 SS | 94.2d | 0d | 29,371.87 | OK | 1.3.3.100 | CONS | CONS | ZONE-3 | COMM | COMM |
| CON-Z3-UTIL-COM-0900 |  | Manhole Frame & Covers | 4d | 2017-05-21 | 2017-05-25 | CON-Z3-UTIL-COM-0890 | 103.2d | 0d | 22,028.9 | OK | 1.3.3.100 | CONS | CONS | ZONE-3 | COMM | COMM |
| CON-Z3-UTIL-COM-0910 |  | Warning Tape & Duct Bank Backfilling | 3d | 2017-05-25 | 2017-05-29 | CON-Z3-UTIL-COM-0900 | 103.2d | 0d | 14,685.94 | OK | 1.3.3.100 | CONS | CONS | ZONE-3 | COMM | COMM |
| CON-Z3-UTIL-COM-0920 |  | Backfilling | 3d | 2017-05-29 | 2017-06-01 | CON-Z3-UTIL-COM-0860 SS, CON-Z3-UTIL-COM-0910 | 103.2d | 4d | 7,342.97 | OK | 1.3.3.100 | CONS | CONS | ZONE-3 | COMM | COMM |

Notes:
- CON-Z3-UTIL-COM-0740: Expenses: (New Expense Item) 45893.6
- CON-Z3-UTIL-COM-0750: Expenses: (New Expense Item) 45893.6
- CON-Z3-UTIL-COM-0760: Expenses: (New Expense Item) 36714.8
- CON-Z3-UTIL-COM-0770: Expenses: (New Expense Item) 22028.9
- CON-Z3-UTIL-COM-0780: Expenses: (New Expense Item) 14685.9
- CON-Z3-UTIL-COM-0790: Expenses: (New Expense Item) 36714.8
- CON-Z3-UTIL-COM-0800: Expenses: (New Expense Item) 36714.8
- CON-Z3-UTIL-COM-0810: Expenses: (New Expense Item) 36714.8
- CON-Z3-UTIL-COM-0820: Expenses: (New Expense Item) 22028.9
- CON-Z3-UTIL-COM-0830: Expenses: (New Expense Item) 14685.9
- CON-Z3-UTIL-COM-0840: Expenses: (New Expense Item) 36714.8
- CON-Z3-UTIL-COM-0850: Expenses: (New Expense Item) 22028.9
- CON-Z3-UTIL-COM-0860: Expenses: (New Expense Item) 14685.9
- CON-Z3-UTIL-COM-0870: Expenses: (New Expense Item) 36714.8
- CON-Z3-UTIL-COM-0880: Expenses: (New Expense Item) 36714.8
- CON-Z3-UTIL-COM-0890: Expenses: (New Expense Item) 29371.9
- CON-Z3-UTIL-COM-0900: Expenses: (New Expense Item) 22028.9
- CON-Z3-UTIL-COM-0910: Expenses: (New Expense Item) 14685.9
- CON-Z3-UTIL-COM-0920: Expenses: (New Expense Item) 7342.97

| ID | WBS | Activity | Type | Duration | Start | Finish | Predecessors | Total float | Free float | Resources | Cost | Wajid | RPI_P2 - BOQ ITEMS | RPI_P2 - CONSTRUCTION | RPI_P2 - PHASE | RPI_P2 - ZONES | RPI_P2 - DISCIPLINE / WORK TYPE | RPI_P2 - UTILITY NETWORK | Activity Wt% | Weight % | Cost Wt | RPI - PHASE | RPI - CONSTRUCTION | RPI - ZONES | RPI - BUILDINGS | RPI - TYPE OF WORK | RPI_P2 - BUILDINGS |
| --- | --- | --- | --- | --- | --- | --- | --- | --- | --- | --- | --- | --- | --- | --- | --- | --- | --- | --- | --- | --- | --- | --- | --- | --- | --- | --- | --- |
|  | 19 | **Remaining Works - Comm. Manhole T-108 Duct Bank Backfilling & MH-1016 & 1017 TYPE-1b** |  |  | 2017-05-21 | 2017-06-06 |  |  |  |  |  |  |  |  |  |  |  |  |  |  |  |  |  |  |  |  |  |
| CON-Z3-UTIL-COM-0930 |  | Manhole Cleaning & Grounding Works |  | 4d | 2017-05-21 | 2017-05-25 | CON-Z3-UTIL-COM-0890 | 94.2d | 0d |  | 29,371.87 | OK | 1.3.3.100 | CONS | CONS | ZONE-3 | COMM | COMM |  |  |  |  |  |  |  |  |  |
| CON-Z3-UTIL-COM-0940 |  | Manhole Frame & Covers |  | 4d | 2017-05-25 | 2017-05-30 | CON-Z3-UTIL-COM-0930 | 99.2d | 0d |  | 22,028.9 | OK | 1.3.3.100 | CONS | CONS | ZONE-3 | COMM | COMM |  |  |  |  |  |  |  |  |  |
| CON-Z3-UTIL-COM-0950 |  | Warning Tape & Duct Bank Backfilling |  | 3d | 2017-05-30 | 2017-06-03 | CON-Z3-UTIL-COM-0940 | 99.2d | 0d |  | 14,685.94 | OK | 1.3.3.100 | CONS | CONS | ZONE-3 | COMM | COMM |  |  |  |  |  |  |  |  |  |
| CON-Z3-UTIL-COM-0960 |  | Backfilling |  | 3d | 2017-06-03 | 2017-06-06 | CON-Z3-UTIL-COM-0950, CON-Z3-UTIL-COM-0920 SS | 99.2d | 1d |  | 7,342.97 | OK | 1.3.3.100 | CONS | CONS | ZONE-3 | COMM | COMM |  |  |  |  |  |  |  |  |  |
|  | 20 | **Remaining Works - Comm. Manhole T-113 MH-1008 TYPE-1b** |  |  | 2017-05-25 | 2017-06-07 |  |  |  |  |  |  |  |  |  |  |  |  |  |  |  |  |  |  |  |  |  |
| CON-Z3-UTIL-COM-0970 |  | Manhole Cleaning & Grounding Works |  | 4d | 2017-05-25 | 2017-05-30 | CON-Z3-UTIL-COM-0930 | 94.2d | 0d |  | 36,714.84 | OK | 1.3.3.100 | CONS | CONS | ZONE-3 | COMM | COMM |  |  |  |  |  |  |  |  |  |
| CON-Z3-UTIL-COM-0980 |  | Manhole Frame & Covers |  | 4d | 2017-05-30 | 2017-06-04 | CON-Z3-UTIL-COM-0970 | 98.2d | 0d |  | 22,028.9 | OK | 1.3.3.100 | CONS | CONS | ZONE-3 | COMM | COMM |  |  |  |  |  |  |  |  |  |
| CON-Z3-UTIL-COM-0990 |  | Backfilling |  | 3d | 2017-06-04 | 2017-06-07 | CON-Z3-UTIL-COM-0960 SS, CON-Z3-UTIL-COM-0980 | 98.2d | 4d |  | 14,685.94 | OK | 1.3.3.100 | CONS | CONS | ZONE-3 | COMM | COMM |  |  |  |  |  |  |  |  |  |
|  | 21 | **Remaining Works - Comm. Manhole T-114 SMH-94-A TYPE-2a** |  |  | 2017-05-30 | 2017-06-12 |  |  |  |  |  |  |  |  |  |  |  |  |  |  |  |  |  |  |  |  |  |
| CON-Z3-UTIL-COM-1010 |  | Manhole Cleaning & Grounding Works |  | 4d | 2017-05-30 | 2017-06-04 | CON-Z3-UTIL-COM-0970 | 94.2d | 0d |  | 36,714.84 | OK | 1.3.3.100 | CONS | CONS | ZONE-3 | COMM | COMM |  |  |  |  |  |  |  |  |  |
| CON-Z3-UTIL-COM-1020 |  | Manhole Frame & Covers |  | 4d | 2017-06-04 | 2017-06-08 | CON-Z3-UTIL-COM-1010 | 94.2d | 0d |  | 22,028.9 | OK | 1.3.3.100 | CONS | CONS | ZONE-3 | COMM | COMM |  |  |  |  |  |  |  |  |  |
| CON-Z3-UTIL-COM-1030 |  | Backfilling |  | 3d | 2017-06-08 | 2017-06-12 | CON-Z3-UTIL-COM-0990 SS, CON-Z3-UTIL-COM-1020 | 94.2d | 0d |  | 14,685.94 | OK | 1.3.3.100 | CONS | CONS | ZONE-3 | COMM | COMM |  |  |  |  |  |  |  |  |  |
|  | 22 | **Remaining Works - Comm. Manhole T-115 MH-1027 TYPE-1b** |  |  | 2017-06-08 | 2017-06-13 |  |  |  |  |  |  |  |  |  |  |  |  |  |  |  |  |  |  |  |  |  |
| CON-Z3-UTIL-COM-1040 |  | Manhole Cleaning & Grounding Works |  | 4d | 2017-06-08 | 2017-06-13 | CON-Z3-UTIL-COM-1030 SS, CON-Z3-UTIL-COM-1010 | 94.2d | 0d |  | 73,429.68 | OK | 1.3.3.100 | CONS | CONS | ZONE-3 | COMM | COMM |  |  |  |  |  |  |  |  |  |
|  | 23 | **Remaining Works - Comm. Manhole T-116 MH-1027 TYPE-1b** |  |  | 2017-06-13 | 2017-06-18 |  |  |  |  |  |  |  |  |  |  |  |  |  |  |  |  |  |  |  |  |  |
| CON-Z3-UTIL-COM-1050 |  | Manhole Cleaning & Grounding Works |  | 4d | 2017-06-13 | 2017-06-18 | CON-Z3-UTIL-COM-1040 | 94.2d | 0d |  | 73,429.68 | OK | 1.3.3.100 | CONS | CONS | ZONE-3 | COMM | COMM |  |  |  |  |  |  |  |  |  |
|  | 24 | **Remaining Works - Comm. Manhole T-118 & Duct Bank Backfilling** |  |  | 2017-06-18 | 2017-07-09 |  |  |  |  |  |  |  |  |  |  |  |  |  |  |  |  |  |  |  |  |  |
| CON-Z3-UTIL-COM-1060 |  | Manhole Cleaning & Grounding Works |  | 4d | 2017-06-18 | 2017-06-22 | CON-Z3-UTIL-COM-1050 | 94.2d | 0d |  | 29,371.87 | OK | 1.3.3.100 | CONS | CONS | ZONE-3 | COMM | COMM |  |  |  |  |  |  |  |  |  |
| CON-Z3-UTIL-COM-1070 |  | Manhole Frame & Covers |  | 4d | 2017-06-22 | 2017-07-02 | CON-Z3-UTIL-COM-1060 | 94.2d | 0d |  | 22,028.9 | OK | 1.3.3.100 | CONS | CONS | ZONE-3 | COMM | COMM |  |  |  |  |  |  |  |  |  |
| CON-Z3-UTIL-COM-1080 |  | Warning Tape & Duct Bank Backfilling |  | 3d | 2017-07-02 | 2017-07-05 | CON-Z3-UTIL-COM-1070 | 94.2d | 0d | Common Labor / Helper [30 h]; JCB [42 h]; Operator - JCB [30 h]; Roller-Compactor (2~10 Ton) [42 h]; Vibrators [84 h] | 14,685.94 | OK | 1.3.3.100 | CONS | CONS | ZONE-3 | COMM | COMM |  |  |  |  |  |  |  |  |  |
| CON-Z3-UTIL-COM-1090 |  | Backfilling |  | 3d | 2017-07-05 | 2017-07-09 | CON-Z3-UTIL-COM-1080 | 94.2d | 93.8d | JCB [84 h]; Operator - JCB [60 h] | 7,342.97 | OK | 1.3.3.100 | CONS | CONS | ZONE-3 | COMM | COMM |  |  |  |  |  |  |  |  |  |
|  | 2 | **BUILDING WORKS** |  |  | 2016-12-04 | 2017-08-03 |  |  |  |  |  |  |  |  |  |  |  |  |  |  |  |  |  |  |  |  |  |
|  | 1 | **Lift Station no. 10 and 11** |  |  | 2016-12-04 | 2017-08-03 |  |  |  |  |  |  |  |  |  |  |  |  |  |  |  |  |  |  |  |  |  |
|  | 1 | **Lift Station no. 10 & ATS Room for Lift Station** |  |  | 2016-12-04 | 2017-08-03 |  |  |  |  |  |  |  |  |  |  |  |  |  |  |  |  |  |  |  |  |  |
|  | 1 | **Civil & Structural Works** |  |  | 2016-12-04 | 2017-02-18 |  |  |  |  |  |  |  |  |  |  |  |  |  |  |  |  |  |  |  |  |  |
|  | 1 | **Liftstation No. 10** |  |  | 2016-12-04 | 2017-01-26 |  |  |  |  |  |  |  |  |  |  |  |  |  |  |  |  |  |  |  |  |  |
| CON-Z3-LS10-SW-0000 |  | Start of Work for Lift Station # 10 | milestone | 0d | 2016-12-04 | 2016-12-04 | CON-Z3-UT-GRV-PL-210 | 30.2d | 0d |  |  |  | 1.3.4.10 | CONS | CONS | ZONE-3 | CIVIL |  | 0 | 0 | 0 | 6 | RPI - CONS | Z2 | LS12 | CIVIL | LS-10 |
| CON-Z3-LS10-SW-0010 |  | Dewatering for Lift Station # 10 |  | 8d | 2016-12-04 | 2016-12-13 | CON-Z3-LS10-SW-0000 | 30.8d | 0d | Common Labor / Helper [104 h]; Dewatering Pumps [28 h] | 1,000 |  | 1.3.4.10 | CONS | CONS | ZONE-3 | CIVIL |  |  |  |  |  |  |  |  |  | LS-10 |
| CON-Z3-LS10-SW-0030 |  | Concrete Columns / Walls - Steel / Formwork & Concrete above Lift Station # 10 |  | 6.4d | 2016-12-13 | 2016-12-21 | CON-Z3-LS10-SW-0010 | 30.8d | 0d | Steel Fixer [78 h]; Shuttering Carpenter [78 h]; Concrete Mason [78 h]; Common Labor / Helper [52 h]; Scaffolder [52 h]; Driver - Conc. Transit Mixers [26 h]; Operator - Concrete Pump [26 h]; Concrete Transit Mixers [28 h]; Concrete Pump [28 h] | 23,247.96 |  | 1.3.4.10 | CONS | CONS | ZONE-3 | CIVIL |  | 0 | 0 | 0.1338573317 | 6 | RPI - CONS | Z2 | LS12 | CIVIL | LS-10 |
| CON-Z3-LS10-SW-0040 |  | Roof Slab - Shuttering, Steel, Formwork & Concrete above Lift Station # 10 |  | 7.2d | 2016-12-21 | 2016-12-29 | CON-Z3-LS10-SW-0030 | 30.8d | 0d | Steel Fixer [52 h]; Shuttering Carpenter [78 h]; Concrete Mason [78 h]; Common Labor / Helper [78 h]; Scaffolder [78 h] | 6,512.08 |  | 1.3.4.10 | CONS | CONS | ZONE-3 | CIVIL |  | 0 | 0 | 0.0561098933 | 6 | RPI - CONS | Z2 | LS12 | CIVIL | LS-10 |
| CON-Z3-LS10-SW-0050 |  | De-shuttering Roof Slab |  | 2.4d | 2016-12-29 | 2017-01-01 | CON-Z3-LS10-SW-0040 | 97.4d | 0d | Shuttering Carpenter [78 h]; Scaffolder [52 h] | 500 |  | 1.3.4.10 | CONS | CONS | ZONE-3 | CIVIL |  | 0 | 0 | 0.0010581949 | 6 | RPI - CONS | Z2 | LS12 | CIVIL | LS-10 |
| CON-Z3-LS10-SW-0060 |  | Water Proofing roofing system for the roof |  | 4.8d | 2017-01-04 | 2017-01-09 | CON-Z3-LS10-SW-0040 FS+4.8d, PR-Z3-GE-GE-224-0080 | 30.8d | 0d | Water Proofing Crew [52 h] | 22,124.19 |  | 1.3.4.10 | CONS | CONS | ZONE-3 | CIVIL |  | 0 | 0 | 0.046823408 | 6 | RPI - CONS | Z2 | LS12 | CIVIL | LS-10 |
| CON-Z3-LS10-SW-0070 |  | Surface Preparation / External Water proofing for wall |  | 7.2d | 2017-01-10 | 2017-01-18 | CON-Z3-LS10-SW-0040 FS+6.4d, CON-Z3-LS10-SW-0060 | 30.8d | 0d | Common Labor / Helper [52 h]; Scaffolder [52 h]; Water Proofing Crew [52 h]; Finishing Work Crew [52 h]; Roller-Compactor (2~10 Ton) [28 h]; JCB [28 h] | 13,099.01 |  | 1.3.4.10 | CONS | CONS | ZONE-3 | CIVIL |  | 0 | 0 | 0.4514238297 | 6 | RPI - CONS | Z2 | LS12 | CIVIL | LS-10 |
| CON-Z3-LS10-SW-0080 |  | Backfilling around Lift Station # 10 |  | 7.2d | 2017-01-18 | 2017-01-26 | CON-Z3-LS10-SW-0070 | 30.8d | 0d | Common Labor / Helper [78 h]; Operator - Loader [26 h]; Driver - Dump Truck [26 h]; Operator - Bobcat [26 h]; Operator - Roller-Compactor (2~10 Ton) [26 h]; Operator - Roller (25 Ton) [26 h]; Driver - Water Tanker [26 h]; Loader [28 h]; Dump Truck [28 h]; Bobcat [28 h]; Roller-Compactor (2~10 Ton) [28 h]; Roller-Compactor (25 Ton) [28 h]; Water Tanker [28 h] | 10,915.57 |  | 1.3.4.10 | CONS | CONS | ZONE-3 | CIVIL |  | 0 | 0 | 0.0442654971 | 6 | RPI - CONS | Z2 | LS12 | CIVIL | LS-10 |

Notes:
- CON-Z3-UTIL-COM-0930: Expenses: (New Expense Item) 29371.9
- CON-Z3-UTIL-COM-0940: Expenses: (New Expense Item) 22028.9
- CON-Z3-UTIL-COM-0950: Expenses: (New Expense Item) 14685.9
- CON-Z3-UTIL-COM-0960: Expenses: (New Expense Item) 7342.97
- CON-Z3-UTIL-COM-0970: Expenses: (New Expense Item) 36714.8
- CON-Z3-UTIL-COM-0980: Expenses: (New Expense Item) 22028.9
- CON-Z3-UTIL-COM-0990: Expenses: (New Expense Item) 14685.9
- CON-Z3-UTIL-COM-1010: Expenses: (New Expense Item) 36714.8
- CON-Z3-UTIL-COM-1020: Expenses: (New Expense Item) 22028.9
- CON-Z3-UTIL-COM-1030: Expenses: (New Expense Item) 14685.9
- CON-Z3-UTIL-COM-1040: Expenses: (New Expense Item) 73429.7
- CON-Z3-UTIL-COM-1050: Expenses: (New Expense Item) 73429.7
- CON-Z3-UTIL-COM-1060: Expenses: (New Expense Item) 29371.9
- CON-Z3-UTIL-COM-1070: Expenses: (New Expense Item) 22028.9
- CON-Z3-UTIL-COM-1080: Expenses: (New Expense Item) 14685.9
- CON-Z3-UTIL-COM-1090: Expenses: (New Expense Item) 7342.97
- CON-Z3-LS10-SW-0010: Expenses: (New Expense Item) 1000
- CON-Z3-LS10-SW-0030: Expenses: (New Expense Item) 23248
- CON-Z3-LS10-SW-0040: Expenses: (New Expense Item) 6512.08
- CON-Z3-LS10-SW-0050: Expenses: (New Expense Item) 500
- CON-Z3-LS10-SW-0060: Expenses: (New Expense Item) 22124.2
- CON-Z3-LS10-SW-0070: Expenses: (New Expense Item) 13099
- CON-Z3-LS10-SW-0080: Expenses: (New Expense Item) 10915.6

| ID | WBS | Activity | Duration | Start | Finish | Predecessors | Total float | Free float | Resources | Cost | Activity Wt% | Weight % | Cost Wt | RPI - PHASE | RPI - CONSTRUCTION | RPI - ZONES | RPI - BUILDINGS | RPI - TYPE OF WORK | RPI_P2 - BOQ ITEMS | RPI_P2 - CONSTRUCTION | RPI_P2 - PHASE | RPI_P2 - ZONES | RPI_P2 - DISCIPLINE / WORK TYPE | RPI_P2 - BUILDINGS |
| --- | --- | --- | --- | --- | --- | --- | --- | --- | --- | --- | --- | --- | --- | --- | --- | --- | --- | --- | --- | --- | --- | --- | --- | --- |
|  | 2 | **ATS Room for Lift Station No. 10** |  | 2016-12-21 | 2017-02-18 |  |  |  |  |  |  |  |  |  |  |  |  |  |  |  |  |  |  |  |
| CON-Z3-ATSR-CW-0010 |  | Excavation / Grade Beam Excavation | 3.2d | 2016-12-21 | 2016-12-25 | GE-DWG-ENG-ENG-0010, CON-Z3-LS10-SW-0030 | 49.2d | 0d | Operator - Excavator [26 h]; JCB [28 h] | 229.39 | 0 | 0 | 0.0004854786 | 6 | RPI - CONS | Z2 | LS12 | CIVIL | 1.3.4.10 | CONS | CONS | ZONE-3 | CIVIL | LS-10 |
| CON-Z3-ATSR-CW-0020 |  | Bed Preparation / Lean Concrete | 1.6d | 2016-12-25 | 2016-12-26 | CON-Z3-ATSR-CW-0010 | 49.2d | 0d | Concrete Mason [52 h]; Driver - Conc. Transit Mixers [26 h]; Operator - Concrete Pump [26 h] | 351.87 | 0 | 0 | 0.000744694 | 6 | RPI - CONS | Z2 | LS12 | CIVIL | 1.3.4.10 | CONS | CONS | ZONE-3 | CIVIL | LS-10 |
| CON-Z3-ATSR-CW-0040 |  | RC Footing | 4d | 2016-12-27 | 2016-12-31 | CON-Z3-ATSR-CW-0020 | 49.2d | 0d | Steel Fixer [78 h]; Shuttering Carpenter [78 h]; Concrete Mason [78 h]; Mechanical Technician [52 h] | 2,185.22 | 0 | 0 | 0.0046247771 | 6 | RPI - CONS | Z2 | LS12 | CIVIL | 1.3.4.10 | CONS | CONS | ZONE-3 | CIVIL | LS-10 |
| CON-Z3-ATSR-CW-0050 |  | Lean Concrete - grade beam | 0.8d | 2017-01-01 | 2017-01-01 | CON-Z3-ATSR-CW-0040 | 49.2d | 0d | Concrete Mason [52 h]; Driver - Conc. Transit Mixers [26 h]; Operator - Concrete Pump [26 h] | 195.48 | 0 | 0 | 0.0004137119 | 6 | RPI - CONS | Z2 | LS12 | CIVIL | 1.3.4.10 | CONS | CONS | ZONE-3 | CIVIL | LS-10 |
| CON-Z3-ATSR-CW-0060 |  | Concrete Apron / Grade Beam | 3.2d | 2017-01-01 | 2017-01-04 | CON-Z3-ATSR-CW-0050 | 49.2d | 18.4d | Steel Fixer [52 h]; Shuttering Carpenter [78 h]; Concrete Mason [78 h]; Common Labor / Helper [52 h] | 4,489.68 | 0 | 0 | 0.0095019125 | 6 | RPI - CONS | Z2 | LS12 | CIVIL | 1.3.4.10 | CONS | CONS | ZONE-3 | CIVIL | LS-10 |
| CON-Z3-ATSR-CW-0070 |  | Backfilling / Compaction & Testing | 2.4d | 2017-01-26 | 2017-01-29 | CON-Z3-ATSR-CW-0060, CON-Z3-LS10-SW-0080 | 30.8d | 0d | Common Labor / Helper [78 h]; Operator - Loader [26 h]; Driver - Dump Truck [26 h]; Operator - Bobcat [26 h]; Operator - Roller-Compactor (2~10 Ton) [26 h]; Operator - Roller (25 Ton) [26 h]; Driver - Water Tanker [26 h]; Loader [28 h]; Dump Truck [28 h]; Bobcat [28 h]; Roller-Compactor (2~10 Ton) [28 h]; Roller-Compactor (25 Ton) [28 h]; Water Tanker [28 h] | 1,038.55 | 0 | 0 | 0.0021979765 | 6 | RPI - CONS | Z2 | LS12 | CIVIL | 1.3.4.10 | CONS | CONS | ZONE-3 | CIVIL | LS-10 |
| CON-Z3-ATSR-CW-0080 |  | Slab on grade | 3.2d | 2017-01-29 | 2017-02-01 | CON-Z3-ATSR-CW-0070 | 30.8d | 0d | Steel Fixer [52 h]; Shuttering Carpenter [78 h]; Concrete Mason [78 h]; Common Labor / Helper [78 h] | 2,119.3 | 0 | 0 | 0.0044852647 | 6 | RPI - CONS | Z2 | LS12 | CIVIL | 1.3.4.10 | CONS | CONS | ZONE-3 | CIVIL | LS-10 |
| CON-Z3-ATSR-CW-0090 |  | Concrete Columns | 4.8d | 2017-02-02 | 2017-02-07 | CON-Z3-ATSR-CW-0080 | 30.8d | 0d | Steel Fixer [78 h]; Shuttering Carpenter [78 h]; Concrete Mason [78 h]; Common Labor / Helper [52 h]; Scaffolder [52 h]; Driver - Conc. Transit Mixers [26 h]; Operator - Concrete Pump [26 h]; Concrete Transit Mixers [28 h]; Concrete Pump [28 h] | 2,976.65 | 0 | 0 | 0.0062997514 | 6 | RPI - CONS | Z2 | LS12 | CIVIL | 1.3.4.10 | CONS | CONS | ZONE-3 | CIVIL | LS-10 |
| CON-Z3-ATSR-CW-0100 |  | Beams & Roof Slab | 5.6d | 2017-02-07 | 2017-02-14 | CON-Z3-ATSR-CW-0090 | 30.8d | 0d | Steel Fixer [52 h]; Shuttering Carpenter [78 h]; Concrete Mason [78 h]; Common Labor / Helper [78 h]; Scaffolder [78 h] | 6,182.91 | 0 | 0 | 0.0130854471 | 6 | RPI - CONS | Z2 | LS12 | CIVIL | 1.3.4.10 | CONS | CONS | ZONE-3 | CIVIL | LS-10 |
| CON-Z3-ATSR-CW-0110 |  | Parapet Walls | 3.2d | 2017-02-14 | 2017-02-18 | CON-Z3-ATSR-CW-0100 | 30.8d | 0d | Steel Fixer [52 h]; Shuttering Carpenter [78 h]; Concrete Mason [52 h]; Common Labor / Helper [52 h]; Scaffolder [52 h] | 1,960.22 | 0 | 0 | 0.0041485894 | 6 | RPI - CONS | Z2 | LS12 | CIVIL | 1.3.4.10 | CONS | CONS | ZONE-3 | CIVIL | LS-10 |
|  | 2 | **Architectural Works & Finishes** |  | 2017-01-18 | 2017-03-25 |  |  |  |  |  |  |  |  |  |  |  |  |  |  |  |  |  |  |  |
|  | 1 | **Liftstation No. 10** |  | 2017-01-18 | 2017-02-21 |  |  |  |  |  |  |  |  |  |  |  |  |  |  |  |  |  |  |  |
| CON-Z3-LS10-AR-0010 |  | Surface Preparation / Epoxy paint for the wall (Dry & Wet Well) | 16.8d | 2017-01-18 | 2017-02-06 | PR-Z3-GE-GE-218-0080, CON-Z3-LS10-SW-0070 | 40.4d | 0d | Common Labor / Helper [26 h]; Scaffolder [52 h]; Painter [78 h] | 29,779.52 | 0 | 0 | 0.0630250697 | 6 | RPI - CONS | Z2 | LS12 | CIVIL | 1.3.4.10 | CONS | CONS | ZONE-3 | CIVIL | LS-10 |
| CON-Z3-LS10-AR-0020 |  | Surface Preparation / Non Skid epoxy paint for the floor (Dry & Wet Well) | 9.6d | 2017-01-29 | 2017-02-09 | CON-Z3-LS10-AR-0010 SS+9.6d | 40.4d | 0d | Common Labor / Helper [26 h]; Scaffolder [52 h]; Painter [78 h] | 17,624.83 | 0 | 0 | 0.0373010088 | 6 | RPI - CONS | Z2 | LS12 | CIVIL | 1.3.4.10 | CONS | CONS | ZONE-3 | CIVIL | LS-10 |
| CON-Z3-LS10-AR-0030 |  | Wall & Ceiling paint for the room above LS | 6.4d | 2017-02-07 | 2017-02-14 | CON-Z3-LS10-AR-0020 FF+4d | 40.4d | 8.2d | Common Labor / Helper [26 h]; Scaffolder [52 h]; Painter [78 h]; Gypsum Walls & Ceiling Crew [52 h] | 4,542.41 | 0 | 0 | 0.051941304 | 6 | RPI - CONS | Z2 | LS12 | CIVIL | 1.3.4.10 | CONS | CONS | ZONE-3 | CIVIL | LS-10 |
| CON-Z3-LS10-AR-0040 |  | Installation of door frames & doors | 4.8d | 2017-02-16 | 2017-02-21 | CON-Z3-LS10-AR-0030 SS, PR-Z3-GE-GE-227-0080 | 32.2d | 0d | Shuttering Carpenter [52 h]; Common Labor / Helper [26 h] | 8,751.92 | 0 | 0 | 0.0185224734 | 6 | RPI - CONS | Z2 | LS12 | CIVIL | 1.3.4.10 | CONS | CONS | ZONE-3 | CIVIL | LS-10 |
| CON-Z3-LS10-AR-0050 |  | Cage Ladder FRP | 3.2d | 2017-02-16 | 2017-02-20 | CON-Z3-LS10-AR-0040 SS, PR-Z3-GE-GE-225-0080 | 32.2d | 1.4d | Common Labor / Helper [104 h] | 10,723.46 | 0 | 0 | 0.0861867117 | 6 | RPI - CONS | Z2 | LS12 | CIVIL | 1.3.4.10 | CONS | CONS | ZONE-3 | CIVIL | LS-10 |
|  | 2 | **ATS Room for Lift Station No. 10** |  | 2017-02-18 | 2017-03-25 |  |  |  |  |  |  |  |  |  |  |  |  |  |  |  |  |  |  |  |
| CON-Z3-LS10-AR-0060 |  | Block Works | 6.4d | 2017-02-18 | 2017-02-25 | PR-Z3-GE-GE-215-0080, CON-Z3-ATSR-CW-0110, CON-Z3-LS10-AR-0050 SS | 30.8d | 0d | Common Labor / Helper [52 h]; Block Mason [78 h] | 5,131.47 | 0 | 0 | 0.0108601903 | 6 | RPI - CONS | Z2 | LS12 | CIVIL | 1.3.4.10 | CONS | CONS | ZONE-3 | CIVIL | LS-10 |
| CON-Z3-LS10-AR-0070 |  | Plastering - Internal & External | 5.6d | 2017-02-26 | 2017-03-04 | CON-Z3-LS10-AR-0060 | 30.8d | 0d | Concrete Mason [78 h]; Common Labor / Helper [26 h]; Scaffolder [26 h]; Finishing Work Crew [52 h] | 7,697.2 | 0 | 0 | 0.0162902749 | 6 | RPI - CONS | Z2 | LS12 | CIVIL | 1.3.4.10 | CONS | CONS | ZONE-3 | CIVIL | LS-10 |
| CON-Z3-LS10-AR-0080 |  | External Painting | 6.4d | 2017-03-04 | 2017-03-11 | CON-Z3-LS10-AR-0070 | 30.8d | 0d | Common Labor / Helper [26 h]; Scaffolder [52 h]; Painter [78 h] | 5,375.22 | 0 | 0 | 0.0113760603 | 6 | RPI - CONS | Z2 | LS12 | CIVIL | 1.3.4.10 | CONS | CONS | ZONE-3 | CIVIL | LS-10 |
| CON-Z3-LS10-AR-0090 |  | Doors & Windows | 2.4d | 2017-03-12 | 2017-03-14 | PR-Z3-GE-GE-230-0080, CON-Z3-LS10-AR-0080, CON-Z3-LS10-AR-0070 | 30.8d | 0d | Shuttering Carpenter [52 h]; Common Labor / Helper [26 h] | 6,407.55 | 0 | 0 | 0.0135608729 | 6 | RPI - CONS | Z2 | LS12 | CIVIL | 1.3.4.10 | CONS | CONS | ZONE-3 | CIVIL | LS-10 |
| CON-Z3-LS10-AR-0110 |  | Roofing System | 4d | 2017-03-12 | 2017-03-15 | CON-Z3-LS10-AR-0080 | 116.6d | 4d | Common Labor / Helper [52 h]; Water Proofing Crew [52 h]; Finishing Work Crew [52 h] | 8,610.14 | 0 | 0 | 0.0182224117 | 6 | RPI - CONS | Z2 | LS12 | CIVIL | 1.3.4.10 | CONS | CONS | ZONE-3 | CIVIL | LS-10 |
| CON-Z3-LS10-AR-0100 |  | Internal Painting | 5.6d | 2017-03-14 | 2017-03-20 | CON-Z3-LS10-AR-0070, CON-Z3-LS10-AR-0090 | 30.8d | 0d | Common Labor / Helper [26 h]; Scaffolder [52 h]; Painter [78 h] | 3,420.98 | 0 | 0 | 0.0072401269 | 6 | RPI - CONS | Z2 | LS12 | CIVIL | 1.3.4.10 | CONS | CONS | ZONE-3 | CIVIL | LS-10 |
| CON-Z3-LS10-AR-0120 |  | Floor Finishes | 3.2d | 2017-03-21 | 2017-03-25 | CON-Z3-LS10-AR-0110, CON-Z3-LS10-AR-0100 | 112.6d | 82.4d | Common Labor / Helper [52 h]; Finishing Work Crew [52 h] | 794.16 | 0 | 0 | 0.0016807521 | 6 | RPI - CONS | Z2 | LS12 | CIVIL | 1.3.4.10 | CONS | CONS | ZONE-3 | CIVIL | LS-10 |

Notes:
- CON-Z3-ATSR-CW-0010: Expenses: (New Expense Item) 229.39
- CON-Z3-ATSR-CW-0020: Expenses: (New Expense Item) 351.87
- CON-Z3-ATSR-CW-0040: Expenses: (New Expense Item) 2185.22
- CON-Z3-ATSR-CW-0050: Expenses: (New Expense Item) 195.48
- CON-Z3-ATSR-CW-0060: Expenses: (New Expense Item) 4489.68
- CON-Z3-ATSR-CW-0070: Expenses: (New Expense Item) 1038.55
- CON-Z3-ATSR-CW-0080: Expenses: (New Expense Item) 2119.3
- CON-Z3-ATSR-CW-0090: Expenses: (New Expense Item) 2976.65
- CON-Z3-ATSR-CW-0100: Expenses: (New Expense Item) 6182.91
- CON-Z3-ATSR-CW-0110: Expenses: (New Expense Item) 1960.22
- CON-Z3-LS10-AR-0010: Expenses: (New Expense Item) 29779.5
- CON-Z3-LS10-AR-0020: Expenses: (New Expense Item) 17624.8
- CON-Z3-LS10-AR-0030: Expenses: (New Expense Item) 4542.41
- CON-Z3-LS10-AR-0040: Expenses: (New Expense Item) 8751.92
- CON-Z3-LS10-AR-0050: Expenses: (New Expense Item) 10723.5
- CON-Z3-LS10-AR-0060: Expenses: (New Expense Item) 5131.47
- CON-Z3-LS10-AR-0070: Expenses: (New Expense Item) 7697.2
- CON-Z3-LS10-AR-0080: Expenses: (New Expense Item) 5375.22
- CON-Z3-LS10-AR-0090: Expenses: (New Expense Item) 6407.55
- CON-Z3-LS10-AR-0110: Expenses: (New Expense Item) 8610.14
- CON-Z3-LS10-AR-0100: Expenses: (New Expense Item) 3420.98
- CON-Z3-LS10-AR-0120: Expenses: (New Expense Item) 794.16

| ID | WBS | Activity | Duration | Start | Finish | Predecessors | Total float | Free float | Resources | Cost | Activity Wt% | Weight % | Cost Wt | RPI - PHASE | RPI - CONSTRUCTION | RPI - ZONES | RPI - BUILDINGS | RPI - TYPE OF WORK | RPI_P2 - BOQ ITEMS | RPI_P2 - CONSTRUCTION | RPI_P2 - PHASE | RPI_P2 - ZONES | RPI_P2 - DISCIPLINE / WORK TYPE | RPI_P2 - BUILDINGS |
| --- | --- | --- | --- | --- | --- | --- | --- | --- | --- | --- | --- | --- | --- | --- | --- | --- | --- | --- | --- | --- | --- | --- | --- | --- |
|  | 3 | **Mechanical Works** |  | 2017-01-01 | 2017-07-22 |  |  |  |  |  |  |  |  |  |  |  |  |  |  |  |  |  |  |  |
|  | 1 | **Liftstation No. 10** |  | 2017-01-01 | 2017-04-26 |  |  |  |  |  |  |  |  |  |  |  |  |  |  |  |  |  |  |  |
| CON-Z3-LS10-ME-0010 |  | Installation of Plumbing Works | 11.2d | 2017-01-01 | 2017-01-14 | CON-Z3-LS10-SW-0050 | 97.4d | 0d | Plumber [52 h]; Common Labor / Helper [26 h] | 20,886.35 | 0 | 0 | 0.2558426271 | 6 | RPI - CONS | Z2 | LS12 | MECH | 1.3.4.10 | CONS | CONS | ZONE-3 | MECH | LS-10 |
| CON-Z3-LS10-ME-0050 |  | Tie-in for Water Supply | 14.4d | 2017-01-12 | 2017-01-29 | GE-DWG-ENG-ENG-0020, CON-Z3-LS10-ME-0010 SS+9.6d | 176.6d | 0d | Common Labor / Helper [52 h]; Plumber [52 h] | 40,295.45 | 0 | 0 | 0.0852808757 | 6 | RPI - CONS | Z2 | LS12 | MECH | 1.3.4.10 | CONS | CONS | ZONE-3 | MECH | LS-10 |
| CON-Z3-LS10-ME-0020 |  | Installation of pumps & Disconnection Switches at Pump Room Area | 20d | 2017-04-03 | 2017-04-26 | CON-Z3-LS10-ME-0010, PR-Z3-EW-ME-62-0080 | 30.2d | 0d | Electrician [78 h]; Mechanical Technician [26 h]; Operator - Mobile Crane [26 h]; Mobile Crane ( 25-60 Ton) [28 h] | 241,772.7 | 0 | 0 | 0.5116852542 | 6 | RPI - CONS | Z2 | LS12 | MECH | 1.3.4.10 | CONS | CONS | ZONE-3 | MECH | LS-10 |
| CON-Z3-LS10-ME-0030 |  | Installation of Valves | 16.8d | 2017-04-03 | 2017-04-22 | CON-Z3-LS10-ME-0020 SS | 30.2d | 0d | Common Labor / Helper [26 h]; RTR Pipe Crew [26 h] | 80,590.9 | 0 | 0 | 0.1705617514 | 6 | RPI - CONS | Z2 | LS12 | MECH | 1.3.4.10 | CONS | CONS | ZONE-3 | MECH | LS-10 |
| CON-Z3-LS10-ME-0040 |  | Installation of Odor control system in Pump Room Area | 14.4d | 2017-04-03 | 2017-04-19 | PR-Z3-GE-GE-237-0080, CON-Z3-LS10-ME-0030 SS, GE-DWG-ENG-ENG-0050 | 30.2d | 0d | Mechanical Technician [26 h]; Common Labor / Helper [52 h]; HVAC Crew [26 h]; Specialist Works Crew [26 h] | 120,886.35 | 0 | 0 | 0.2558426271 | 6 | RPI - CONS | Z2 | LS12 | MECH | 1.3.4.10 | CONS | CONS | ZONE-3 | MECH | LS-10 |
| CON-Z3-LS10-ME-0060 |  | Installation of Lifting Hoist with Chain in LS-10 | 4d | 2017-04-19 | 2017-04-24 | PR-Z3-GE-GE-226-0080, CON-Z3-LS10-ME-0040 | 30.2d | 0d | Common Labor / Helper [78 h]; Scaffolder [52 h]; Operator - Mobile Crane [26 h]; Mobile Crane ( 25-60 Ton) [28 h] |  |  |  |  |  |  |  |  |  | 1.3.4.10 | CONS | CONS | ZONE-3 | MECH | LS-10 |
|  | 2 | **ATS Room for Lift Station No. 10** |  | 2017-07-03 | 2017-07-22 |  |  |  |  |  |  |  |  |  |  |  |  |  |  |  |  |  |  |  |
| CON-Z3-LS10-ME-0070 |  | Installation of two Package Air Conditioning Units | 15d | 2017-07-03 | 2017-07-20 | PR-Z3-GE-GE-242-0080, CON-Z3-LS10-AR-0120, CON-Z3-LS10-ME-0060 SS+60d | 30.2d | 0d | HVAC Crew [26 h] | 120,886.35 | 0 | 0 | 0.2558426271 | 6 | RPI - CONS | Z2 | LS12 | MECH | 1.3.4.10 | CONS | CONS | ZONE-3 | MECH | LS-10 |
| CON-Z3-LS10-ME-0080 |  | Installation of DDC Panels inside ATS Rooms | 12d | 2017-07-08 | 2017-07-22 | CON-Z3-LS10-ME-0070 SS+4d, PR-Z3-GE-GE-243-0080 | 30.2d | 0d | Electrician [52 h]; Specialist Works Crew [26 h] | 40,295.45 | 0 | 0 | 0.0852808757 | 6 | RPI - CONS | Z2 | LS12 | MECH | 1.3.4.10 | CONS | CONS | ZONE-3 | MECH | LS-10 |
|  | 4 | **Electrical Works** |  | 2017-03-21 | 2017-06-05 |  |  |  |  |  |  |  |  |  |  |  |  |  |  |  |  |  |  |  |
|  | 1 | **Liftstation No. 10** |  | 2017-03-21 | 2017-05-24 |  |  |  |  |  |  |  |  |  |  |  |  |  |  |  |  |  |  |  |
| CON-Z3-LS10-EW-010 |  | Installation of Conduits, Race Ways, Junction Boxes | 20.8d | 2017-03-21 | 2017-04-13 | PR-Z3-GE-GE-249-0080, CON-Z3-LS10-AR-0100 | 30.8d | 0d | Electrician [78 h]; LC Crew [52 h] | 17,441 | 0 | 0 | 0.0369119529 | 6 | RPI - CONS | Z2 | LS12 | ELEC | 1.3.4.10 | CONS | CONS | ZONE-3 | ELEC | LS-10 |
| CON-Z3-LS10-EW-020 |  | LV / MV Cables & Wire Pulling | 16.8d | 2017-03-26 | 2017-04-15 | PR-Z3-EW-EW-55-0080, CON-Z3-LS10-EW-010 SS+4.8d | 77.4d | 0d | Electrician [78 h]; LC Crew [52 h] | 31,946.8 | 0 | 0 | 0.0676118788 | 6 | RPI - CONS | Z2 | LS12 | ELEC | 1.3.4.10 | CONS | CONS | ZONE-3 | ELEC | LS-10 |
| CON-Z3-LS10-EW-030 |  | Installation of Ultrasonic Level Sensor / Controller at LS-10 | 20d | 2017-03-28 | 2017-04-20 | CON-Z3-LS10-EW-020 SS+1.6d | 77.4d | 0d | Electrician [78 h]; LC Crew [52 h] | 6,056.55 | 0 | 0 | 0.0128180201 | 6 | RPI - CONS | Z2 | LS12 | ELEC | 1.3.4.10 | CONS | CONS | ZONE-3 | ELEC | LS-10 |
| CON-Z3-LS10-EW-040 |  | Installation of LV Panel Boards, Equipments | 20d | 2017-04-20 | 2017-05-14 | CON-Z3-LS10-EW-020 SS+4.8d, CON-Z3-LS10-EW-030 | 77.4d | 0d | Electrician [78 h]; LC Crew [52 h] | 34,882 | 0 | 0 | 0.0738239058 | 6 | RPI - CONS | Z2 | LS12 | ELEC | 1.3.4.10 | CONS | CONS | ZONE-3 | ELEC | LS-10 |
| CON-Z3-LS10-EW-050 |  | Installation of Wiring Devices, Outlets, Switches , Lighting Fixtures | 20d | 2017-05-02 | 2017-05-24 | PR-Z3-GE-GE-250-0080, CON-Z3-LS10-EW-040 SS+9.6d | 77.4d | 0d | Electrician [78 h]; LC Crew [52 h] | 52,323 | 0 | 0 | 0.1107358588 | 6 | RPI - CONS | Z2 | LS12 | ELEC | 1.3.4.10 | CONS | CONS | ZONE-3 | ELEC | LS-10 |
| CON-Z3-LS10-EW-060 |  | Installation of Audible Alarm on Lift Station | 16.8d | 2017-05-02 | 2017-05-21 | CON-Z3-LS10-EW-050 SS, CON-Z3-LS10-EW-040 SS | 77.4d | 36d | Electrician [78 h]; LC Crew [52 h] | 3,560 | 0 | 0 | 0.0075343474 | 6 | RPI - CONS | Z2 | LS12 | ELEC | 1.3.4.10 | CONS | CONS | ZONE-3 | ELEC | LS-10 |
|  | 2 | **ATS Room for Lift Station No. 10** |  | 2017-04-13 | 2017-06-05 |  |  |  |  |  |  |  |  |  |  |  |  |  |  |  |  |  |  |  |
| CON-Z3-LS10-ELE-0010 |  | Installation of Cable ways, Conduits, Boxes (for Power & Control Cables) | 9.6d | 2017-04-13 | 2017-04-25 | CON-Z3-LS10-AR-0100, CON-Z3-LS10-EW-010 | 30.8d | 0d | Electrician [78 h]; LC Crew [52 h] | 17,441 | 0 | 0 | 0.0369119529 | 6 | RPI - CONS | Z2 | LS12 | ELEC | 1.3.4.10 | CONS | CONS | ZONE-3 | ELEC | LS-10 |
| CON-Z3-LS10-ELE-0020 |  | LV / MV Cables & Wire Pulling | 14.4d | 2017-04-19 | 2017-05-06 | CON-Z3-LS10-ELE-0010 SS+4.8d | 30.8d | 0d | Electrician [78 h]; LC Crew [52 h] | 31,946.8 | 0 | 0 | 0.0676118788 | 6 | RPI - CONS | Z2 | LS12 | ELEC | 1.3.4.10 | CONS | CONS | ZONE-3 | ELEC | LS-10 |
| CON-Z3-LS10-ELE-0030 |  | Installation of Direct Buried Cable from Transformer to Circuit Breakers | 12d | 2017-05-07 | 2017-05-20 | CON-Z3-LS10-ELE-0020 | 64.6d | 0d | Electrician [78 h]; LC Crew [52 h] | 129,018 | 0 | 0 | 0.2730523675 | 6 | RPI - CONS | Z2 | LS12 | ELEC | 1.3.4.10 | CONS | CONS | ZONE-3 | ELEC | LS-10 |
| CON-Z3-LS10-ELE-0040 |  | Installation of Lighting Poles (Remaining Works) | 12d | 2017-05-07 | 2017-05-20 | CON-Z3-LS10-ELE-0030 SS, PR-Z3-EW-EW-43-0080 | 64.6d | 0d | Electrician [78 h]; LC Crew [52 h] | 30,342 | 0 | 0 | 0.0642154966 | 6 | RPI - CONS | Z2 | LS12 | ELEC | 1.3.4.10 | CONS | CONS | ZONE-3 | ELEC | LS-10 |
| CON-Z3-LS10-ELE-0060 |  | LV / MV Cable Dressing, termination of Transformer including grounding | 14.4d | 2017-05-07 | 2017-05-23 | CON-Z3-LS10-ELE-0020 SS, PR-Z3-EW-EW-38-0080, CON-Z3-LS10-ELE-0040 SS | 64.6d | 0d | Electrician [78 h]; LC Crew [52 h] | 43,757.5 | 0 | 0 | 0.1137718198 | 6 | RPI - CONS | Z2 | LS12 | ELEC | 1.3.4.10 | CONS | CONS | ZONE-3 | ELEC | LS-10 |
| CON-Z3-LS10-ELE-0070 |  | Cable Dressing, Termination & Testing from Circuit Breaker to Motor Control Center | 14.4d | 2017-05-07 | 2017-05-23 | CON-Z3-LS10-ELE-0060 SS | 64.6d | 0d | Electrician [78 h]; LC Crew [52 h] | 7,986.7 | 0 | 0 | 0.0169029697 | 6 | RPI - CONS | Z2 | LS12 | ELEC | 1.3.4.10 | CONS | CONS | ZONE-3 | ELEC | LS-10 |
| CON-Z3-LS10-ELE-0080 |  | Cable Dressing, Termination & Testing from ATS LS-10 to Emergency Generator | 14.4d | 2017-05-07 | 2017-05-23 | CON-Z3-LS10-ELE-0070 SS | 64.6d | 0d | Electrician [78 h]; LC Crew [52 h] | 3,993.35 | 0 | 0 | 0.0084514848 | 6 | RPI - CONS | Z2 | LS12 | ELEC | 1.3.4.10 | CONS | CONS | ZONE-3 | ELEC | LS-10 |
| CON-Z3-LS10-ELE-0090 |  | Cable Dressing, Termination & Testing from MCC to Pumps thru Starter | 14.4d | 2017-05-07 | 2017-05-23 | CON-Z3-LS10-ELE-0080 SS | 64.6d | 0d | Electrician [78 h]; LC Crew [52 h] | 3,993.35 | 0 | 0 | 0.0084514848 | 6 | RPI - CONS | Z2 | LS12 | ELEC | 1.3.4.10 | CONS | CONS | ZONE-3 | ELEC | LS-10 |
| CON-Z3-LS10-ELE-0100 |  | Installation of Grid Grounding, Equipment Grounding | 12d | 2017-05-09 | 2017-05-23 | CON-Z3-LS10-ELE-0090 SS+2.4d | 64.6d | 0d | Electrician [78 h]; LC Crew [52 h] | 13,567 | 0 | 0 | 0.0287130592 | 6 | RPI - CONS | Z2 | LS12 | ELEC | 1.3.4.10 | CONS | CONS | ZONE-3 | ELEC | LS-10 |
| CON-Z3-LS10-ELE-0110 |  | Installation of LV Panel Boards | 7.2d | 2017-05-09 | 2017-05-17 | CON-Z3-LS10-ELE-0020 SS, CON-Z3-LS10-ELE-0100 SS | 64.6d | 0d | Electrician [78 h]; LC Crew [52 h] | 34,882 | 0 | 0 | 0.0738239058 | 6 | RPI - CONS | Z2 | LS12 | ELEC | 1.3.4.10 | CONS | CONS | ZONE-3 | ELEC | LS-10 |
| CON-Z3-LS10-ELE-0120 |  | Installation of Equipments including 13.8 kv Transformer (MCC, ATS, CP, DDCP, CB ..) | 16.8d | 2017-05-09 | 2017-05-29 | CON-Z3-LS10-ELE-0110 SS, PR-Z3-EW-EW-48-0080, PR-Z3-GE-GE-243-0080, CON-Z3-LS10-ELE-0060 SS | 71d | 6.4d | Electrician [78 h]; LC Crew [52 h] | 8,720.5 | 0 | 0 | 0.0184559765 | 6 | RPI - CONS | Z2 | LS12 | ELEC | 1.3.4.10 | CONS | CONS | ZONE-3 | ELEC | LS-10 |
| CON-Z3-LS10-ELE-0130 |  | Installation of Lighting Fixtures, Wiring Devices, Outlets, Disconnect Switches | 12d | 2017-05-16 | 2017-05-30 | CON-Z3-LS10-ELE-0120 SS, PR-Z3-EW-ME-62-0080, PR-Z3-EW-EW-44-0080, PR-Z4-CW-CW-169-0080, CON-Z3-LS10-ELE-0110 SS+6.4d | 64.6d | 0d | Electrician [78 h]; LC Crew [52 h] | 8,720.5 | 0 | 0 | 0.0184559765 | 6 | RPI - CONS | Z2 | LS12 | ELEC | 1.3.4.10 | CONS | CONS | ZONE-3 | ELEC | LS-10 |
| CON-Z3-LS10-ELE-0140 |  | Installation of Fire Alarm System including FACP, Detectors, Pull Station & Accessories | 16.8d | 2017-05-16 | 2017-06-05 | PR-Z3-GE-GE-244-0080, CON-Z3-LS10-ELE-0110 SS, CON-Z3-LS10-ELE-0130 SS | 64.6d | 0d | Electrician [78 h]; LC Crew [52 h] | 6,105.6 | 0 | 0 | 0.012921829 | 6 | RPI - CONS | Z2 | LS12 | ELEC | 1.3.4.10 | CONS | CONS | ZONE-3 | ELEC | LS-10 |
| CON-Z3-LS10-ELE-0150 |  | Installation of Ultrasonic Level Sensor / Controller at LS-10 | 16.8d | 2017-05-16 | 2017-06-05 | CON-Z3-LS10-ELE-0140 SS | 64.6d | 23.2d | Electrician [78 h]; LC Crew [52 h] | 6,056.55 | 0 | 0 | 0.0128180201 | 6 | RPI - CONS | Z2 | LS12 | ELEC | 1.3.4.10 | CONS | CONS | ZONE-3 | ELEC | LS-10 |

Notes:
- CON-Z3-LS10-ME-0010: Expenses: (New Expense Item) 20886.3
- CON-Z3-LS10-ME-0050: Expenses: (New Expense Item) 40295.4
- CON-Z3-LS10-ME-0020: Expenses: (New Expense Item) 241773
- CON-Z3-LS10-ME-0030: Expenses: (New Expense Item) 80590.9
- CON-Z3-LS10-ME-0040: Expenses: (New Expense Item) 120886
- CON-Z3-LS10-ME-0070: Expenses: (New Expense Item) 120886
- CON-Z3-LS10-ME-0080: Expenses: (New Expense Item) 40295.4
- CON-Z3-LS10-EW-010: Expenses: (New Expense Item) 17441
- CON-Z3-LS10-EW-020: Expenses: (New Expense Item) 31946.8
- CON-Z3-LS10-EW-030: Expenses: (New Expense Item) 6056.55
- CON-Z3-LS10-EW-040: Expenses: (New Expense Item) 34882
- CON-Z3-LS10-EW-050: Expenses: (New Expense Item) 52323
- CON-Z3-LS10-EW-060: Expenses: (New Expense Item) 3560
- CON-Z3-LS10-ELE-0010: Expenses: (New Expense Item) 17441
- CON-Z3-LS10-ELE-0020: Expenses: (New Expense Item) 31946.8
- CON-Z3-LS10-ELE-0030: Expenses: (New Expense Item) 129018
- CON-Z3-LS10-ELE-0040: Expenses: (New Expense Item) 30342
- CON-Z3-LS10-ELE-0060: Expenses: (New Expense Item) 43757.5
- CON-Z3-LS10-ELE-0070: Expenses: (New Expense Item) 7986.7
- CON-Z3-LS10-ELE-0080: Expenses: (New Expense Item) 3993.35
- CON-Z3-LS10-ELE-0090: Expenses: (New Expense Item) 3993.35
- CON-Z3-LS10-ELE-0100: Expenses: (New Expense Item) 13567
- CON-Z3-LS10-ELE-0110: Expenses: (New Expense Item) 34882
- CON-Z3-LS10-ELE-0120: Expenses: (New Expense Item) 8720.5
- CON-Z3-LS10-ELE-0130: Expenses: (New Expense Item) 8720.5
- CON-Z3-LS10-ELE-0140: Expenses: (New Expense Item) 6105.6
- CON-Z3-LS10-ELE-0150: Expenses: (New Expense Item) 6056.55

| ID | WBS | Activity | Type | Duration | Start | Finish | Predecessors | Total float | Free float | Resources | Cost | Activity Wt% | Weight % | Cost Wt | RPI - PHASE | RPI - CONSTRUCTION | RPI - ZONES | RPI - BUILDINGS | RPI - TYPE OF WORK | RPI_P2 - BOQ ITEMS | RPI_P2 - CONSTRUCTION | RPI_P2 - PHASE | RPI_P2 - ZONES | RPI_P2 - DISCIPLINE / WORK TYPE | RPI_P2 - BUILDINGS |
| --- | --- | --- | --- | --- | --- | --- | --- | --- | --- | --- | --- | --- | --- | --- | --- | --- | --- | --- | --- | --- | --- | --- | --- | --- | --- |
|  | 7 | **External Works** |  |  | 2017-05-07 | 2017-08-03 |  |  |  |  |  |  |  |  |  |  |  |  |  |  |  |  |  |  |  |
| CON-Z3-LS10-EW-0010 |  | Cable Trench for Main feeder of LS # 10 to Transformer |  | 7.2d | 2017-05-07 | 2017-05-15 | CON-Z3-LS10-ELE-0020 | 30.8d | 0d | Electrician [78 h]; LC Crew [52 h] | 7,652 | 0 | 0 | 0.0161946141 | 6 | RPI - CONS | Z2 | LS12 | CIVIL | 1.3.4.10 | CONS | CONS | ZONE-3 | CIVIL | LS-10 |
| CON-Z3-LS10-EW-0020 |  | Installation of Pad Mounted Transformer for Power Supply of LS-10 |  | 7.2d | 2017-05-15 | 2017-05-23 | CON-Z3-LS10-EW-0010 | 30.8d | 0d |  | 7,652 | 0 | 0 | 0.0161946141 | 6 | RPI - CONS | Z2 | LS12 | CIVIL | 1.3.4.10 | CONS | CONS | ZONE-3 | CIVIL | LS-10 |
| CON-Z3-LS10-EW-0030 |  | Installation of concrete padestal for Emergency Generator |  | 8d | 2017-05-15 | 2017-05-24 | CON-Z3-LS10-EW-0020 SS | 30.8d | 0d | Steel Fixer [78 h]; Shuttering Carpenter [78 h]; Concrete Mason [78 h]; Common Labor / Helper [52 h] | 4,214.88 | 0 | 0 | 0.0089203287 | 6 | RPI - CONS | Z2 | LS12 | CIVIL | 1.3.4.10 | CONS | CONS | ZONE-3 | CIVIL | LS-10 |
| CON-Z3-LS10-EW-0040 |  | Installation of Diesel Generator and Dummy Loads |  | 14.4d | 2017-05-24 | 2017-06-10 | CON-Z3-LS10-EW-0030 | 30.8d | 0d | Mechanical Technician [26 h]; Operator - Mobile Crane [26 h]; Mobile Crane ( 25-60 Ton) [28 h] | 21,503 | 0 | 0 | 0.0455087279 | 6 | RPI - CONS | Z2 | LS12 | CIVIL | 1.3.4.10 | CONS | CONS | ZONE-3 | CIVIL | LS-10 |
| CON-Z3-LS10-EW-0050 |  | Installation of Concrete Side Walks near electrical Room |  | 9.6d | 2017-05-24 | 2017-06-04 | CON-Z3-LS10-EW-0040 SS, CON-Z3-LS10-EW-0030 SS | 30.8d | 0d | Mechanical Technician [26 h]; Operator - Mobile Crane [26 h]; Mobile Crane ( 25-60 Ton) [28 h] | 5,000 | 0 | 0 | 0.0105819485 | 6 | RPI - CONS | Z2 | LS12 | CIVIL | 1.3.4.10 | CONS | CONS | ZONE-3 | CIVIL | LS-10 |
| CON-Z3-LS10-EW-0060 |  | Construction of Concrete Valve Box |  | 7.2d | 2017-05-24 | 2017-06-01 | CON-Z3-LS10-EW-0050 SS | 30.8d | 0d | Steel Fixer [78 h]; Shuttering Carpenter [78 h]; Concrete Mason [78 h]; Mechanical Technician [52 h] | 1,221.7 | 0 | 0 | 0.0025855933 | 6 | RPI - CONS | Z2 | LS12 | CIVIL | 1.3.4.10 | CONS | CONS | ZONE-3 | CIVIL | LS-10 |
| CON-Z3-LS10-EW-0070 |  | General Backfilling for LS-10 Area |  | 5.6d | 2017-05-29 | 2017-06-04 | CON-Z3-LS10-EW-0060 SS+4d | 30.8d | 0d | Common Labor / Helper [78 h]; Operator - Loader [26 h]; Driver - Dump Truck [26 h]; Operator - Bobcat [26 h]; Operator - Roller-Compactor (2~10 Ton) [26 h]; Operator - Roller (25 Ton) [26 h]; Driver - Water Tanker [26 h]; Loader [28 h]; Dump Truck [28 h]; Bobcat [28 h]; Roller-Compactor (2~10 Ton) [28 h]; Roller-Compactor (25 Ton) [28 h]; Water Tanker [28 h] | 71,446.93 | 0 | 0 | 0.1723734445 | 6 | RPI - CONS | Z2 | LS12 | CIVIL | 1.3.4.10 | CONS | CONS | ZONE-3 | CIVIL | LS-10 |
| CON-Z3-LS10-EW-0080 |  | Installation of curb stone |  | 6.4d | 2017-06-04 | 2017-06-12 | CON-Z3-LS10-EW-0070, CON-Z3-LS10-EW-0030 SS, PR-Z3-CW-CW-21-0080 | 30.8d | 0d | Steel Fixer [78 h]; Shuttering Carpenter [78 h]; Concrete Mason [78 h]; Mechanical Technician [52 h] | 13,825.56 | 0 | 0 | 0.0292602729 | 6 | RPI - CONS | Z2 | LS12 | CIVIL | 1.3.4.10 | CONS | CONS | ZONE-3 | CIVIL | LS-10 |
| CON-Z3-LS10-EW-0090 |  | Installation of Precast fence @ LS-10 |  | 14.4d | 2017-07-08 | 2017-07-25 | PR-Z3-GE-GE-222-0080, CON-Z3-LS10-EW-0080 SS+25d | 30.8d | 0d | Common Labor / Helper [78 h]; Fence Crew - Lift Station [78 h]; Operator - Mobile Crane [26 h]; Mobile Crane ( 25-60 Ton) [28 h] | 534,115.03 | 0 | 0 | 1.1635207345 | 6 | RPI - CONS | Z2 | LS12 | CIVIL | 1.3.4.10 | CONS | CONS | ZONE-3 | CIVIL | LS-10 |
| CON-Z3-LS10-EW-0100 |  | Installation of Steel Gate (Gate swing 4850 mm, small gate 1200mm) |  | 4d | 2017-07-22 | 2017-07-26 | PR-Z3-GE-GE-223-0080, CON-Z3-LS10-EW-0090 FF+1.6d | 33.2d | 2.4d | Common Labor / Helper [52 h]; Operator - Boom Truck (15 Ton) [26 h]; Mobile Crane ( 25-60 Ton) [28 h]; Boom Truck (15 Ton) [28 h] | 25,384.29 | 0 | 0 | 0.0537230501 | 6 | RPI - CONS | Z2 | LS12 | CIVIL | 1.3.4.10 | CONS | CONS | ZONE-3 | CIVIL | LS-10 |
| CON-Z3-LS10-EW-0110 |  | Asphalt pavement at Lift Station # 10 Area |  | 5.6d | 2017-07-25 | 2017-07-31 | CON-Z3-LS10-EW-0080, CON-Z3-LS10-EW-0070, CON-Z3-LS10-EW-0090, CON-Z3-LS10-EW-0100 SS | 30.8d | 0d | Common Labor / Helper [52 h]; Road Works Crew [52 h]; Operator - Asphalt Paver [56 h]; Operator - Asphalt Compactor / Roller [56 h]; Operator - Roller (25 Ton) [56 h] | 66,786.48 | 0 | 0 | 0.141346219 | 6 | RPI - CONS | Z2 | LS12 | CIVIL | 1.3.4.10 | CONS | CONS | ZONE-3 | CIVIL | LS-10 |
| CON-Z3-LS10-EW-0120 |  | Road Marking at Lift Station # 10 Area |  | 3.2d | 2017-07-31 | 2017-08-03 | CON-Z3-LS10-EW-0110 | 30.8d | 0d | Common Labor / Helper [104 h] | 1,357.45 | 0 | 0 | 0.0028728932 | 6 | RPI - CONS | Z2 | LS12 | CIVIL | 1.3.4.10 | CONS | CONS | ZONE-3 | CIVIL | LS-10 |
| CON-Z3-LS10-EW-0130 |  | Traffic Sign at Lift Station # 10 Area |  | 2.4d | 2017-07-31 | 2017-08-03 | CON-Z3-LS10-EW-0120 SS, CON-Z3-LS10-EW-0110, PR-Z3-CW-MS-28-0080 | 30.8d | 0.6d | Shuttering Carpenter [26 h]; Common Labor / Helper [52 h] | 3,868.73 | 0 | 0 | 0.0081877404 | 6 | RPI - CONS | Z2 | LS12 | CIVIL | 1.3.4.10 | CONS | CONS | ZONE-3 | CIVIL | LS-10 |
|  | 8 | **Testing & Pre-Commissioning** |  |  | 2017-01-29 | 2017-08-03 |  |  |  |  |  |  |  |  |  |  |  |  |  |  |  |  |  |  |  |
| RPI-Z3-LS10-TC-0050 |  | Hydro Testing - Plumbing Works - LS#10 |  | 9.6d | 2017-01-29 | 2017-02-09 | CON-Z3-LS10-ME-0050 | 176.6d | 146.4d | Plumber [26 h]; Common Labor / Helper [52 h]; Driver - Water Tanker [26 h]; Water Tanker [28 h] | 4,029.55 | 0 | 0 | 0.0085280982 | 6 | RPI - CONS | Z2 | LS12 | MECH | 1.3.4.10 | CONS | CONS | ZONE-3 | ELEC | LS-10 |
| RPI-Z3-LS10-TC-0030 |  | Testing & Pre-commissioning of Electrical Works - LS#10 |  | 12.8d | 2017-07-06 | 2017-07-22 | CON-Z3-LS10-ME-0080 FF, CON-Z3-LS10-EW-060, CON-Z3-LS10-ELE-0150 | 41.4d | 11.2d | Electrician [78 h]; LC Crew [52 h] | 11,743.5 | 0 | 0 | 0.0248538226 | 6 | RPI - CONS | Z2 | LS12 | ELEC | 1.3.4.10 | CONS | CONS | ZONE-3 | ELEC | LS-10 |
| RPI-Z3-LS10-TC-0010 |  | Testing & Balancing of HVAC System - LS#10 |  | 11.2d | 2017-07-20 | 2017-08-02 | CON-Z3-LS10-ME-0070 | 31.2d | 1d | Mechanical Technician [26 h]; HVAC Crew [26 h] | 12,088.64 | 0 | 0 | 0.0255842733 | 6 | RPI - CONS | Z2 | LS12 | MECH | 1.3.4.10 | CONS | CONS | ZONE-3 | ELEC | LS-10 |
| RPI-Z3-LS10-TC-0020 |  | Testing & Pre-commissioning of Mechanical Works - LS#10 |  | 11.2d | 2017-07-22 | 2017-08-03 | CON-Z3-LS10-ME-0040, RPI-Z3-LS10-TC-0010 SS, CON-Z3-LS10-ME-0080 | 30.2d | 0d | Mechanical Technician [52 h]; Specialist Works Crew [26 h] | 24,177.27 | 0 | 0 | 0.0511685254 | 6 | RPI - CONS | Z2 | LS12 | MECH | 1.3.4.10 | CONS | CONS | ZONE-3 | ELEC | LS-10 |
| RPI-Z3-LS10-TC-0060 |  | Mechanical Completion of LS#10 | milestone | 0d | 2017-08-03 | 2017-08-03 | RPI-Z3-LS10-TC-0010 FF, RPI-Z3-LS10-TC-0020, RPI-Z3-LS10-TC-0050, RPI-Z3-LS10-TC-0030, RPI-Z3-LS10-TC-0010, CON-Z3-LS10-EW-0130 | 30.2d | 0d |  |  | 0 | 0 | 0 | 6 | RPI - CONS | Z2 | LS12 | CIVIL | 1.3.4.10 | CONS | CONS | ZONE-3 | ELEC | LS-10 |
|  | 9 | **Lift Station no. 11 & ATS Room for Lift Station** |  |  | 2016-12-18 | 2017-08-03 |  |  |  |  |  |  |  |  |  |  |  |  |  |  |  |  |  |  |  |
|  | 1 | **Civil & Structural Works** |  |  | 2016-12-18 | 2017-02-11 |  |  |  |  |  |  |  |  |  |  |  |  |  |  |  |  |  |  |  |
|  | 1 | **Liftstation No. 11** |  |  | 2016-12-18 | 2017-01-18 |  |  |  |  |  |  |  |  |  |  |  |  |  |  |  |  |  |  |  |
| CON-Z3-LS11-SW-010 |  | Start of Work for Lift Station # 11 | milestone | 0d | 2016-12-18 | 2016-12-18 | CON-Z3-LS10-SW-0000 FS+12d | 30.2d | 0d |  |  | 0 | 0 | 0 | 6 | RPI - CONS | Z2 | LS12 | CIVIL | 1.3.4.10 | CONS | CONS | ZONE-3 | CIVIL | LS-11 |
| CON-Z3-LS11-SW-020 |  | Dewatering for Lift Station # 11 |  | 8d | 2016-12-18 | 2016-12-27 | CON-Z3-LS11-SW-010 | 30.2d | 0d | Dewatering Pumps [224 h]; Common Labor / Helper [104 h] | 1,000 |  |  |  |  |  |  |  |  | 1.3.4.10 | CONS | CONS | ZONE-3 | CIVIL | LS-11 |
| CON-Z3-LS11-SW-070 |  | Water Proofing roofing system for the roof |  | 4.8d | 2016-12-27 | 2017-01-02 | CON-Z3-LS11-SW-020 | 30.2d | 0d | Water Proofing Crew [52 h] | 22,124.19 | 0 | 0 | 0.046823408 | 6 | RPI - CONS | Z2 | LS12 | CIVIL | 1.3.4.10 | CONS | CONS | ZONE-3 | CIVIL | LS-11 |
| CON-Z3-LS11-SW-080 |  | Surface Preparation / External Water proofing for wall |  | 7.2d | 2017-01-02 | 2017-01-10 | CON-Z3-LS11-SW-070 | 30.2d | 0d | Common Labor / Helper [52 h]; Scaffolder [52 h]; Water Proofing Crew [52 h]; Finishing Work Crew [52 h]; Roller-Compactor (2~10 Ton) [28 h]; JCB [28 h] | 13,099.01 | 0 | 0 | 0.4514238297 | 6 | RPI - CONS | Z2 | LS12 | CIVIL | 1.3.4.10 | CONS | CONS | ZONE-3 | CIVIL | LS-11 |
| CON-Z3-LS11-SW-090 |  | Backfilling around Lift Station # 11 |  | 7.2d | 2017-01-10 | 2017-01-18 | CON-Z3-LS11-SW-080 | 30.2d | 0d | Common Labor / Helper [78 h]; Operator - Loader [26 h]; Driver - Dump Truck [26 h]; Operator - Bobcat [26 h]; Operator - Roller-Compactor (2~10 Ton) [26 h]; Operator - Roller (25 Ton) [26 h]; Driver - Water Tanker [26 h]; Loader [28 h]; Dump Truck [28 h]; Bobcat [28 h]; Roller-Compactor (2~10 Ton) [28 h]; Roller-Compactor (25 Ton) [28 h]; Water Tanker [28 h] | 10,915.57 | 0 | 0 | 0.0442654971 | 6 | RPI - CONS | Z2 | LS12 | CIVIL | 1.3.4.10 | CONS | CONS | ZONE-3 | CIVIL | LS-11 |

Notes:
- CON-Z3-LS10-EW-0010: Expenses: (New Expense Item) 7652
- CON-Z3-LS10-EW-0020: Expenses: (New Expense Item) 7652
- CON-Z3-LS10-EW-0030: Expenses: (New Expense Item) 4214.88
- CON-Z3-LS10-EW-0040: Expenses: (New Expense Item) 21503
- CON-Z3-LS10-EW-0050: Expenses: (New Expense Item) 5000
- CON-Z3-LS10-EW-0060: Expenses: (New Expense Item) 1221.7
- CON-Z3-LS10-EW-0070: Expenses: (New Expense Item) 71446.9
- CON-Z3-LS10-EW-0080: Expenses: (New Expense Item) 13825.6
- CON-Z3-LS10-EW-0090: Expenses: (New Expense Item) 534115
- CON-Z3-LS10-EW-0100: Expenses: (New Expense Item) 25384.3
- CON-Z3-LS10-EW-0110: Expenses: (New Expense Item) 66786.5
- CON-Z3-LS10-EW-0120: Expenses: (New Expense Item) 1357.45
- CON-Z3-LS10-EW-0130: Expenses: (New Expense Item) 3868.73
- RPI-Z3-LS10-TC-0050: Expenses: (New Expense Item) 4029.55
- RPI-Z3-LS10-TC-0030: Expenses: (New Expense Item) 11743.5
- RPI-Z3-LS10-TC-0010: Expenses: (New Expense Item) 12088.6
- RPI-Z3-LS10-TC-0020: Expenses: (New Expense Item) 24177.3
- CON-Z3-LS11-SW-020: Expenses: (New Expense Item) 1000
- CON-Z3-LS11-SW-070: Expenses: (New Expense Item) 22124.2
- CON-Z3-LS11-SW-080: Expenses: (New Expense Item) 13099
- CON-Z3-LS11-SW-090: Expenses: (New Expense Item) 10915.6

| ID | WBS | Activity | Duration | Start | Finish | Predecessors | Total float | Free float | Resources | Cost | Activity Wt% | Weight % | Cost Wt | RPI - PHASE | RPI - CONSTRUCTION | RPI - ZONES | RPI - BUILDINGS | RPI - TYPE OF WORK | RPI_P2 - BOQ ITEMS | RPI_P2 - CONSTRUCTION | RPI_P2 - PHASE | RPI_P2 - ZONES | RPI_P2 - DISCIPLINE / WORK TYPE | RPI_P2 - BUILDINGS | Wajid |
| --- | --- | --- | --- | --- | --- | --- | --- | --- | --- | --- | --- | --- | --- | --- | --- | --- | --- | --- | --- | --- | --- | --- | --- | --- | --- |
|  | 2 | **ATS Room for Lift Station No. 11** |  | 2016-12-18 | 2017-02-11 |  |  |  |  |  |  |  |  |  |  |  |  |  |  |  |  |  |  |  |  |
| CON-Z3-ATSR-CW-010 |  | Excavation / Grade Beam Excavation | 3.2d | 2016-12-18 | 2016-12-21 | CON-Z3-LS11-SW-010 | 44.6d | 0d | Operator - Excavator [64 h]; JCB [89.6 h] | 229.39 | 0 | 0 | 0.0004854786 | 6 | RPI - CONS | Z2 | LS12 | CIVIL | 1.3.4.10 | CONS | CONS | ZONE-3 | CIVIL | LS-11 |  |
| CON-Z3-ATSR-CW-020 |  | Bed Preparation / Lean Concrete | 1.6d | 2016-12-22 | 2016-12-24 | CON-Z3-ATSR-CW-010 | 44.6d | 0d | Concrete Mason [52 h]; Driver - Conc. Transit Mixers [26 h]; Operator - Concrete Pump [26 h] | 351.87 | 0 | 0 | 0.000744694 | 6 | RPI - CONS | Z2 | LS12 | CIVIL | 1.3.4.10 | CONS | CONS | ZONE-3 | CIVIL | LS-11 |  |
| CON-Z3-ATSR-CW-030 |  | RC Footing | 4d | 2016-12-24 | 2016-12-28 | CON-Z3-ATSR-CW-020 | 44.6d | 0d | Steel Fixer [78 h]; Shuttering Carpenter [78 h]; Concrete Mason [78 h]; Mechanical Technician [52 h] | 2,185.22 | 0 | 0 | 0.0046247771 | 6 | RPI - CONS | Z2 | LS12 | CIVIL | 1.3.4.10 | CONS | CONS | ZONE-3 | CIVIL | LS-11 |  |
| CON-Z3-ATSR-CW-040 |  | Lean Concrete - grade beam | 0.8d | 2016-12-28 | 2016-12-29 | CON-Z3-ATSR-CW-030 | 44.6d | 0d | Concrete Mason [52 h]; Driver - Conc. Transit Mixers [26 h]; Operator - Concrete Pump [26 h] | 195.48 | 0 | 0 | 0.0004137119 | 6 | RPI - CONS | Z2 | LS12 | CIVIL | 1.3.4.10 | CONS | CONS | ZONE-3 | CIVIL | LS-11 |  |
| CON-Z3-ATSR-CW-050 |  | Concrete Apron / Grade Beam | 3.2d | 2016-12-29 | 2017-01-02 | CON-Z3-ATSR-CW-040 | 44.6d | 14.4d | Steel Fixer [52 h]; Shuttering Carpenter [78 h]; Concrete Mason [78 h]; Common Labor / Helper [52 h] | 4,489.68 | 0 | 0 | 0.0095019125 | 6 | RPI - CONS | Z2 | LS12 | CIVIL | 1.3.4.10 | CONS | CONS | ZONE-3 | CIVIL | LS-11 |  |
| CON-Z3-ATSR-CW-060 |  | Backfilling / Compaction & Testing | 2.4d | 2017-01-19 | 2017-01-22 | CON-Z3-LS11-SW-090, CON-Z3-ATSR-CW-050 | 30.2d | 0d | Common Labor / Helper [78 h]; Operator - Loader [26 h]; Driver - Dump Truck [26 h]; Operator - Bobcat [26 h]; Operator - Roller-Compactor (2~10 Ton) [26 h]; Operator - Roller (25 Ton) [26 h]; Driver - Water Tanker [26 h]; Loader [28 h]; Dump Truck [28 h]; Bobcat [28 h]; Roller-Compactor (2~10 Ton) [28 h]; Roller-Compactor (25 Ton) [28 h]; Water Tanker [28 h] | 1,038.55 | 0 | 0 | 0.0021979765 | 6 | RPI - CONS | Z2 | LS12 | CIVIL | 1.3.4.10 | CONS | CONS | ZONE-3 | CIVIL | LS-11 |  |
| CON-Z3-ATSR-CW-070 |  | Slab on grade | 3.2d | 2017-01-22 | 2017-01-25 | CON-Z3-ATSR-CW-060 | 30.2d | 0d | Steel Fixer [52 h]; Shuttering Carpenter [78 h]; Concrete Mason [78 h]; Common Labor / Helper [78 h] | 2,119.3 | 0 | 0 | 0.0044852647 | 6 | RPI - CONS | Z2 | LS12 | CIVIL | 1.3.4.10 | CONS | CONS | ZONE-3 | CIVIL | LS-11 |  |
| CON-Z3-ATSR-CW-080 |  | Concrete Columns | 4.8d | 2017-01-25 | 2017-01-31 | CON-Z3-ATSR-CW-070 | 30.2d | 0d | Operator - Concrete Pump [26 h]; Concrete Transit Mixers [28 h]; Concrete Pump [28 h]; Steel Fixer [78 h]; Shuttering Carpenter [78 h]; Concrete Mason [78 h]; Common Labor / Helper [52 h]; Scaffolder [52 h]; Driver - Conc. Transit Mixers [26 h] | 2,976.65 | 0 | 0 | 0.0062997514 | 6 | RPI - CONS | Z2 | LS12 | CIVIL | 1.3.4.10 | CONS | CONS | ZONE-3 | CIVIL | LS-11 |  |
| CON-Z3-ATSR-CW-090 |  | Beams & Roof Slab | 5.6d | 2017-01-31 | 2017-02-06 | CON-Z3-ATSR-CW-080 | 30.2d | 0d | Steel Fixer [52 h]; Shuttering Carpenter [78 h]; Concrete Mason [78 h]; Common Labor / Helper [78 h]; Scaffolder [78 h] | 6,182.91 | 0 | 0 | 0.0130854471 | 6 | RPI - CONS | Z2 | LS12 | CIVIL | 1.3.4.10 | CONS | CONS | ZONE-3 | CIVIL | LS-11 |  |
| CON-Z3-ATSR-CW-100 |  | Parapet Walls | 3.2d | 2017-02-07 | 2017-02-11 | CON-Z3-ATSR-CW-090 | 30.2d | 0d | Steel Fixer [52 h]; Shuttering Carpenter [78 h]; Concrete Mason [52 h]; Common Labor / Helper [52 h]; Scaffolder [52 h] | 1,960.22 | 0 | 0 | 0.0041485894 | 6 | RPI - CONS | Z2 | LS12 | CIVIL | 1.3.4.10 | CONS | CONS | ZONE-3 | CIVIL | LS-11 |  |
|  | 2 | **Architectural Works & Finishes** |  | 2017-01-10 | 2017-03-28 |  |  |  |  |  |  |  |  |  |  |  |  |  |  |  |  |  |  |  |  |
|  | 1 | **Liftstation No. 11** |  | 2017-01-10 | 2017-02-06 |  |  |  |  |  |  |  |  |  |  |  |  |  |  |  |  |  |  |  |  |
| CON-Z3-LS11-AR-010 |  | Surface Preparation / Epoxy paint for the wall (Dry & Wet Well) | 16.8d | 2017-01-10 | 2017-01-30 | CON-Z3-LS11-SW-080 | 51.8d | 0d | Common Labor / Helper [26 h]; Scaffolder [52 h]; Painter [78 h] | 29,779.52 | 0 | 0 | 0.0630250697 | 6 | RPI - CONS | Z2 | LS12 | CIVIL | 1.3.4.10 | CONS | CONS | ZONE-3 | CIVIL | LS-11 |  |
| CON-Z3-LS11-AR-020 |  | Surface Preparation / Non Skid epoxy paint for the floor (Dry & Wet Well) | 9.6d | 2017-01-22 | 2017-02-01 | CON-Z3-LS11-AR-010 SS+9.6d | 51.8d | 0d | Common Labor / Helper [26 h]; Scaffolder [52 h]; Painter [78 h] | 17,624.83 | 0 | 0 | 0.0373010088 | 6 | RPI - CONS | Z2 | LS12 | CIVIL | 1.3.4.10 | CONS | CONS | ZONE-3 | CIVIL | LS-11 |  |
| CON-Z3-LS11-AR-030 |  | Wall & Ceiling paint for the room above LS | 6.4d | 2017-01-30 | 2017-02-06 | CON-Z3-LS11-AR-020 FF+4d | 51.8d | 0d | Common Labor / Helper [26 h]; Scaffolder [52 h]; Painter [78 h]; Gypsum Walls & Ceiling Crew [52 h] | 4,542.41 | 0 | 0 | 0.051941304 | 6 | RPI - CONS | Z2 | LS12 | CIVIL | 1.3.4.10 | CONS | CONS | ZONE-3 | CIVIL | LS-11 |  |
| CON-Z3-LS11-AR-040 |  | Installation of door frames & doors | 4.8d | 2017-01-30 | 2017-02-05 | CON-Z3-LS11-AR-030 SS | 51.8d | 0d | Shuttering Carpenter [52 h]; Common Labor / Helper [26 h] | 8,751.92 | 0 | 0 | 0.0185224734 | 6 | RPI - CONS | Z2 | LS12 | CIVIL | 1.3.4.10 | CONS | CONS | ZONE-3 | CIVIL | LS-11 |  |
| CON-Z3-LS11-AR-050 |  | Cage Ladder FRP | 3.2d | 2017-01-30 | 2017-02-02 | CON-Z3-LS11-AR-040 SS | 51.8d | 21.6d | Common Labor / Helper [104 h] | 10,723.46 | 0 | 0 | 0.0861867117 | 6 | RPI - CONS | Z2 | LS12 | CIVIL | 1.3.4.10 | CONS | CONS | ZONE-3 | CIVIL | LS-11 |  |
|  | 2 | **ATS Room for Lift Station No. 11** |  | 2017-02-11 | 2017-03-28 |  |  |  |  |  |  |  |  |  |  |  |  |  |  |  |  |  |  |  |  |
| CON-Z3-LS11-AR-060 |  | Block Works | 12d | 2017-02-11 | 2017-02-25 | CON-Z3-ATSR-CW-100 | 30.2d | 0d | Common Labor / Helper [52 h]; Block Mason [78 h] | 5,131.47 | 0 | 0 | 0.0108601903 | 6 | RPI - CONS | Z2 | LS12 | CIVIL | 1.3.4.10 | CONS | CONS | ZONE-3 | CIVIL | LS-11 | OK |
| CON-Z3-LS11-AR-070 |  | Plastering - Internal & External | 8d | 2017-02-25 | 2017-03-06 | CON-Z3-LS11-AR-060, CON-Z3-LS11-AR-050 SS | 30.2d | 0d | Concrete Mason [78 h]; Common Labor / Helper [26 h]; Scaffolder [26 h]; Finishing Work Crew [52 h] | 7,697.2 | 0 | 0 | 0.0162902749 | 6 | RPI - CONS | Z2 | LS12 | CIVIL | 1.3.4.10 | CONS | CONS | ZONE-3 | CIVIL | LS-11 | OK |
| CON-Z3-LS11-AR-080 |  | External Painting | 6.4d | 2017-03-06 | 2017-03-13 | CON-Z3-LS11-AR-070 | 30.2d | 0d | Common Labor / Helper [26 h]; Scaffolder [52 h]; Painter [78 h] | 5,375.22 | 0 | 0 | 0.0113760603 | 6 | RPI - CONS | Z2 | LS12 | CIVIL | 1.3.4.10 | CONS | CONS | ZONE-3 | CIVIL | LS-11 | OK |
| CON-Z3-LS11-AR-090 |  | Doors & Windows | 4d | 2017-03-13 | 2017-03-18 | CON-Z3-LS11-AR-070, CON-Z3-LS11-AR-080 | 30.2d | 0d | Shuttering Carpenter [52 h]; Common Labor / Helper [26 h] | 6,407.55 | 0 | 0 | 0.0135608729 | 6 | RPI - CONS | Z2 | LS12 | CIVIL | 1.3.4.10 | CONS | CONS | ZONE-3 | CIVIL | LS-11 | OK |
| CON-Z3-LS11-AR-110 |  | Water Prrofing & Roofing System | 8d | 2017-03-13 | 2017-03-22 | CON-Z3-LS11-AR-080 | 55.4d | 1.6d | Common Labor / Helper [52 h]; Water Proofing Crew [52 h]; Finishing Work Crew [52 h] | 8,610.14 | 0 | 0 | 0.0182224117 | 6 | RPI - CONS | Z2 | LS12 | CIVIL | 1.3.4.10 | CONS | CONS | ZONE-3 | CIVIL | LS-11 | OK |
| CON-Z3-LS11-AR-100 |  | Internal Painting | 5.6d | 2017-03-18 | 2017-03-25 | CON-Z3-LS11-AR-090, CON-Z3-LS11-AR-070 | 30.2d | 0d | Common Labor / Helper [26 h]; Scaffolder [52 h]; Painter [78 h] | 3,420.98 | 0 | 0 | 0.0072401269 | 6 | RPI - CONS | Z2 | LS12 | CIVIL | 1.3.4.10 | CONS | CONS | ZONE-3 | CIVIL | LS-11 | OK |
| CON-Z3-LS11-AR-120 |  | Floor Finishes | 3.2d | 2017-03-25 | 2017-03-28 | CON-Z3-LS11-AR-100, CON-Z3-LS11-AR-110 | 53.8d | 0d | Common Labor / Helper [52 h]; Finishing Work Crew [52 h] | 794.16 | 0 | 0 | 0.0016807521 | 6 | RPI - CONS | Z2 | LS12 | CIVIL | 1.3.4.10 | CONS | CONS | ZONE-3 | CIVIL | LS-11 | OK |

Notes:
- CON-Z3-ATSR-CW-010: Expenses: (New Expense Item) 229.39
- CON-Z3-ATSR-CW-020: Expenses: (New Expense Item) 351.87
- CON-Z3-ATSR-CW-030: Expenses: (New Expense Item) 2185.22
- CON-Z3-ATSR-CW-040: Expenses: (New Expense Item) 195.48
- CON-Z3-ATSR-CW-050: Expenses: (New Expense Item) 4489.68
- CON-Z3-ATSR-CW-060: Expenses: (New Expense Item) 1038.55
- CON-Z3-ATSR-CW-070: Expenses: (New Expense Item) 2119.3
- CON-Z3-ATSR-CW-080: Expenses: (New Expense Item) 2976.65
- CON-Z3-ATSR-CW-090: Expenses: (New Expense Item) 6182.91
- CON-Z3-ATSR-CW-100: Expenses: (New Expense Item) 1960.22
- CON-Z3-LS11-AR-010: Expenses: (New Expense Item) 29779.5
- CON-Z3-LS11-AR-020: Expenses: (New Expense Item) 17624.8
- CON-Z3-LS11-AR-030: Expenses: (New Expense Item) 4542.41
- CON-Z3-LS11-AR-040: Expenses: (New Expense Item) 8751.92
- CON-Z3-LS11-AR-050: Expenses: (New Expense Item) 10723.5
- CON-Z3-LS11-AR-060: Expenses: (New Expense Item) 5131.47
- CON-Z3-LS11-AR-070: Expenses: (New Expense Item) 7697.2
- CON-Z3-LS11-AR-080: Expenses: (New Expense Item) 5375.22
- CON-Z3-LS11-AR-090: Expenses: (New Expense Item) 6407.55
- CON-Z3-LS11-AR-110: Expenses: (New Expense Item) 8610.14
- CON-Z3-LS11-AR-100: Expenses: (New Expense Item) 3420.98
- CON-Z3-LS11-AR-120: Expenses: (New Expense Item) 794.16

| ID | WBS | Activity | Duration | Start | Finish | Predecessors | Total float | Free float | Resources | Cost | Activity Wt% | Weight % | Cost Wt | RPI - PHASE | RPI - CONSTRUCTION | RPI - ZONES | RPI - BUILDINGS | RPI - TYPE OF WORK | RPI_P2 - BOQ ITEMS | RPI_P2 - CONSTRUCTION | RPI_P2 - PHASE | RPI_P2 - ZONES | RPI_P2 - DISCIPLINE / WORK TYPE | RPI_P2 - BUILDINGS |
| --- | --- | --- | --- | --- | --- | --- | --- | --- | --- | --- | --- | --- | --- | --- | --- | --- | --- | --- | --- | --- | --- | --- | --- | --- |
|  | 3 | **Mechanical Works** |  | 2016-12-27 | 2017-06-18 |  |  |  |  |  |  |  |  |  |  |  |  |  |  |  |  |  |  |  |
|  | 1 | **Liftstation No. 11** |  | 2016-12-27 | 2017-02-11 |  |  |  |  |  |  |  |  |  |  |  |  |  |  |  |  |  |  |  |
| CON-Z3-LS11-ME-010 |  | Installation of Plumbing Works | 11.2d | 2016-12-27 | 2017-01-09 | CON-Z3-LS11-SW-010, CON-Z3-LS11-SW-020 | 173.4d | 0d | Plumber [52 h]; Common Labor / Helper [26 h] | 51,146.37 | 0 | 0 | 0.2558426271 | 6 | RPI - CONS | Z2 | LS12 | MECH | 1.3.4.10 | CONS | CONS | ZONE-3 | MECH | LS-11 |
| CON-Z3-LS11-ME-050 |  | Tie-in for Water Supply | 14.4d | 2017-01-08 | 2017-01-24 | CON-Z3-LS11-ME-010 SS+9.6d | 180.6d | 0d | Plumber [52 h]; Common Labor / Helper [52 h] | 40,295.45 | 0 | 0 | 0.0852808757 | 6 | RPI - CONS | Z2 | LS12 | MECH | 1.3.4.10 | CONS | CONS | ZONE-3 | MECH | LS-11 |
| CON-Z3-LS11-ME-020 |  | Installation of pumps & Disconnection Switches at Pump Room Area | 20d | 2017-01-10 | 2017-02-01 | CON-Z3-LS11-ME-010 | 173.4d | 0d | Electrician [78 h]; Mechanical Technician [26 h]; Operator - Mobile Crane [26 h]; Mobile Crane ( 25-60 Ton) [28 h] | 241,772.7 | 0 | 0 | 0.5116852542 | 6 | RPI - CONS | Z2 | LS12 | MECH | 1.3.4.10 | CONS | CONS | ZONE-3 | MECH | LS-11 |
| CON-Z3-LS11-ME-030 |  | Installation of Valves | 16.8d | 2017-01-10 | 2017-01-29 | CON-Z3-LS11-ME-020 SS | 173.4d | 9.2d | Common Labor / Helper [26 h]; RTR Pipe Crew [26 h] | 80,590.9 | 0 | 0 | 0.1705617514 | 6 | RPI - CONS | Z2 | LS12 | MECH | 1.3.4.10 | CONS | CONS | ZONE-3 | MECH | LS-11 |
| CON-Z3-LS11-ME-040 |  | Installation of Odor control system in Pump Room Area | 14.4d | 2017-01-21 | 2017-02-06 | PR-Z3-GE-GE-237-0080, CON-Z3-LS11-ME-030 SS | 164.2d | 0d | Mechanical Technician [26 h]; Common Labor / Helper [52 h]; HVAC Crew [26 h]; Specialist Works Crew [26 h] | 120,886.35 | 0 | 0 | 0.2558426271 | 6 | RPI - CONS | Z2 | LS12 | MECH | 1.3.4.10 | CONS | CONS | ZONE-3 | MECH | LS-11 |
| CON-Z3-LS11-ME-060 |  | Installation of Lifting Hoist with Chain in LS-10 | 4d | 2017-02-06 | 2017-02-11 | CON-Z3-LS11-ME-040 | 164.2d | 108.8d | Common Labor / Helper [78 h]; Scaffolder [52 h]; Operator - Mobile Crane [26 h]; Mobile Crane ( 25-60 Ton) [28 h] |  |  |  |  |  |  |  |  |  | 1.3.4.10 | CONS | CONS | ZONE-3 | MECH | LS-11 |
|  | 2 | **ATS Room for Lift Station No. 11** |  | 2017-06-01 | 2017-06-18 |  |  |  |  |  |  |  |  |  |  |  |  |  |  |  |  |  |  |  |
| CON-Z3-LS11-ME-070 |  | Installation of two Package Air Conditioning Units | 12d | 2017-06-01 | 2017-06-15 | CON-Z3-LS11-AR-120 FS+56d, PR-Z3-GE-GE-242-0080 | 53.8d | 0d | HVAC Crew [26 h] | 120,886.35 | 0 | 0 | 0.2558426271 | 6 | RPI - CONS | Z2 | LS12 | MECH | 1.3.4.10 | CONS | CONS | ZONE-3 | MECH | LS-11 |
| CON-Z3-LS11-ME-080 |  | Installation of DDC Panels inside ATS Rooms | 10d | 2017-06-06 | 2017-06-18 | CON-Z3-LS11-ME-070 SS+4d | 53.8d | 0d | Electrician [52 h]; Specialist Works Crew [26 h] | 40,295.45 | 0 | 0 | 0.0852808757 | 6 | RPI - CONS | Z2 | LS12 | MECH | 1.3.4.10 | CONS | CONS | ZONE-3 | MECH | LS-11 |
|  | 4 | **Electrical Works** |  | 2017-03-25 | 2017-06-21 |  |  |  |  |  |  |  |  |  |  |  |  |  |  |  |  |  |  |  |
|  | 1 | **Liftstation No. 11** |  | 2017-03-25 | 2017-05-29 |  |  |  |  |  |  |  |  |  |  |  |  |  |  |  |  |  |  |  |
| CON-Z3-LS11-EW-010 |  | Installation of Conduits, Race Ways, Junction Boxes | 20.8d | 2017-03-25 | 2017-04-17 | CON-Z3-LS11-AR-100, PR-Z3-GE-GE-249-0080 | 30.2d | 0d | Electrician [78 h]; LC Crew [52 h] | 17,441 | 0 | 0 | 0.0369119529 | 6 | RPI - CONS | Z2 | LS12 | ELEC | 1.3.4.10 | CONS | CONS | ZONE-3 | ELEC | LS-11 |
| CON-Z3-LS11-EW-020 |  | LV / MV Cables & Wire Pulling | 16.8d | 2017-03-30 | 2017-04-18 | CON-Z3-LS11-EW-010 SS+4.8d, PR-Z3-EW-EW-55-0080 | 74.2d | 0d | Electrician [78 h]; LC Crew [52 h] | 31,946.8 | 0 | 0 | 0.0676118788 | 6 | RPI - CONS | Z2 | LS12 | ELEC | 1.3.4.10 | CONS | CONS | ZONE-3 | ELEC | LS-11 |
| CON-Z3-LS11-EW-030 |  | Installation of Ultrasonic Level Sensor / Controller at LS-11 | 20d | 2017-04-01 | 2017-04-24 | CON-Z3-LS11-EW-020 SS+1.6d | 74.2d | 0d | Electrician [78 h]; LC Crew [52 h] | 6,056.55 | 0 | 0 | 0.0128180201 | 6 | RPI - CONS | Z2 | LS12 | ELEC | 1.3.4.10 | CONS | CONS | ZONE-3 | ELEC | LS-11 |
| CON-Z3-LS11-EW-040 |  | Installation of LV Panel Boards, Equipments | 20d | 2017-04-24 | 2017-05-17 | CON-Z3-LS11-EW-030, CON-Z3-LS11-EW-020 SS+4.8d | 74.2d | 0d | Electrician [78 h]; LC Crew [52 h] | 34,882 | 0 | 0 | 0.0738239058 | 6 | RPI - CONS | Z2 | LS12 | ELEC | 1.3.4.10 | CONS | CONS | ZONE-3 | ELEC | LS-11 |
| CON-Z3-LS11-EW-050 |  | Installation of Wiring Devices, Outlets, Switches , Lighting Fixtures | 20d | 2017-05-06 | 2017-05-29 | CON-Z3-LS11-EW-040 SS+9.6d, PR-Z3-GE-GE-250-0080 | 74.2d | 0d | Electrician [78 h]; LC Crew [52 h] | 52,323 | 0 | 0 | 0.1107358588 | 6 | RPI - CONS | Z2 | LS12 | ELEC | 1.3.4.10 | CONS | CONS | ZONE-3 | ELEC | LS-11 |
| CON-Z3-LS11-EW-060 |  | Installation of Audible Alarm on Lift Station | 16.8d | 2017-05-06 | 2017-05-24 | CON-Z3-LS11-EW-040 SS, CON-Z3-LS11-EW-050 SS | 74.2d | 23.2d | Electrician [78 h]; LC Crew [52 h] | 3,560 | 0 | 0 | 0.0075343474 | 6 | RPI - CONS | Z2 | LS12 | ELEC | 1.3.4.10 | CONS | CONS | ZONE-3 | ELEC | LS-11 |
|  | 2 | **ATS Room for Lift Station No. 11** |  | 2017-04-18 | 2017-06-21 |  |  |  |  |  |  |  |  |  |  |  |  |  |  |  |  |  |  |  |
| CON-Z3-LS11-ELE-010 |  | Installation of Cable ways, Conduits, Boxes (for Power & Control Cables) | 9.6d | 2017-04-18 | 2017-04-29 | CON-Z3-LS11-EW-010, CON-Z3-LS11-AR-100 | 30.2d | 0d | Electrician [78 h]; LC Crew [52 h] | 17,441 | 0 | 0 | 0.0369119529 | 6 | RPI - CONS | Z2 | LS12 | ELEC | 1.3.4.10 | CONS | CONS | ZONE-3 | ELEC | LS-11 |
| CON-Z3-LS11-ELE-020 |  | LV / MV Cables & Wire Pulling | 14.4d | 2017-04-23 | 2017-05-10 | CON-Z3-LS11-ELE-010 SS+4.8d | 30.2d | 0d | Electrician [78 h]; LC Crew [52 h] | 31,946.8 | 0 | 0 | 0.0676118788 | 6 | RPI - CONS | Z2 | LS12 | ELEC | 1.3.4.10 | CONS | CONS | ZONE-3 | ELEC | LS-11 |
| CON-Z3-LS11-ELE-030 |  | Installation of Direct Buried Cable from Transformer to Circuit Breakers | 12d | 2017-05-10 | 2017-05-24 | CON-Z3-LS11-ELE-020 | 30.2d | 0d | Electrician [78 h]; LC Crew [52 h] | 129,018 | 0 | 0 | 0.2730523675 | 6 | RPI - CONS | Z2 | LS12 | ELEC | 1.3.4.10 | CONS | CONS | ZONE-3 | ELEC | LS-11 |
| CON-Z3-LS11-ELE-040 |  | Installation of Lighting Poles (Remaining Works) | 12d | 2017-05-10 | 2017-05-24 | CON-Z3-LS11-ELE-030 SS | 30.2d | 0d | Electrician [78 h]; LC Crew [52 h] | 30,342 | 0 | 0 | 0.0642154966 | 6 | RPI - CONS | Z2 | LS12 | ELEC | 1.3.4.10 | CONS | CONS | ZONE-3 | ELEC | LS-11 |
| CON-Z3-LS11-ELE-050 |  | LV / MV Cable Dressing, termination of Transformer including grounding | 14.4d | 2017-05-10 | 2017-05-27 | CON-Z3-LS11-ELE-020 SS, CON-Z3-LS11-ELE-040 SS | 30.2d | 0d | Electrician [78 h]; LC Crew [52 h] | 43,757.5 | 0 | 0 | 0.1137718198 | 6 | RPI - CONS | Z2 | LS12 | ELEC | 1.3.4.10 | CONS | CONS | ZONE-3 | ELEC | LS-11 |
| CON-Z3-LS11-ELE-060 |  | Cable Dressing, Termination & Testing from Circuit Breaker to Motor Control Center | 14.4d | 2017-05-10 | 2017-05-27 | CON-Z3-LS11-ELE-050 SS | 30.2d | 0d | Electrician [78 h]; LC Crew [52 h] | 7,986.7 | 0 | 0 | 0.0169029697 | 6 | RPI - CONS | Z2 | LS12 | ELEC | 1.3.4.10 | CONS | CONS | ZONE-3 | ELEC | LS-11 |
| CON-Z3-LS11-ELE-070 |  | Cable Dressing, Termination & Testing from ATS LS-11 to Emergency Generator | 14.4d | 2017-05-10 | 2017-05-27 | CON-Z3-LS11-ELE-060 SS | 30.2d | 0d | Electrician [78 h]; LC Crew [52 h] | 3,993.35 | 0 | 0 | 0.0084514848 | 6 | RPI - CONS | Z2 | LS12 | ELEC | 1.3.4.10 | CONS | CONS | ZONE-3 | ELEC | LS-11 |
| CON-Z3-LS11-ELE-080 |  | Cable Dressing, Termination & Testing from MCC to Pumps thru Starter | 14.4d | 2017-05-10 | 2017-05-27 | CON-Z3-LS11-ELE-070 SS | 30.2d | 0d | Electrician [78 h]; LC Crew [52 h] | 3,993.35 | 0 | 0 | 0.0084514848 | 6 | RPI - CONS | Z2 | LS12 | ELEC | 1.3.4.10 | CONS | CONS | ZONE-3 | ELEC | LS-11 |
| CON-Z3-LS11-ELE-090 |  | Installation of Grid Grounding, Equipment Grounding | 12d | 2017-05-13 | 2017-05-27 | CON-Z3-LS11-ELE-080 SS+2.4d | 51d | 0d | Electrician [78 h]; LC Crew [52 h] | 13,567 | 0 | 0 | 0.0287130592 | 6 | RPI - CONS | Z2 | LS12 | ELEC | 1.3.4.10 | CONS | CONS | ZONE-3 | ELEC | LS-11 |
| CON-Z3-LS11-ELE-100 |  | Installation of LV Panel Boards | 7.2d | 2017-05-13 | 2017-05-21 | CON-Z3-LS11-ELE-090 SS, CON-Z3-LS11-ELE-020 SS | 51d | 0d | Electrician [78 h]; LC Crew [52 h] | 34,882 | 0 | 0 | 0.0738239058 | 6 | RPI - CONS | Z2 | LS12 | ELEC | 1.3.4.10 | CONS | CONS | ZONE-3 | ELEC | LS-11 |
| CON-Z3-LS11-ELE-110 |  | Installation of Equipments including 13.8 kv Transformer (MCC, ATS, CP, DDCP, CB ..) | 16.8d | 2017-05-13 | 2017-06-01 | PR-Z3-EW-EW-48-0080, CON-Z3-LS11-ELE-050 SS, CON-Z3-LS11-ELE-100 SS | 51d | 0d | Electrician [78 h]; LC Crew [52 h] | 8,720.5 | 0 | 0 | 0.0184559765 | 6 | RPI - CONS | Z2 | LS12 | ELEC | 1.3.4.10 | CONS | CONS | ZONE-3 | ELEC | LS-11 |
| CON-Z3-LS11-ELE-120 |  | Installation of Lighting Fixtures, Wiring Devices, Outlets, Disconnect Switches | 12d | 2017-06-01 | 2017-06-15 | PR-Z3-EW-EW-44-0080, CON-Z3-LS11-ELE-100 SS+6.4d, PR-Z4-CW-CW-169-0080, CON-Z3-LS11-ELE-110 | 51d | 0d | Electrician [78 h]; LC Crew [52 h] | 8,720.5 | 0 | 0 | 0.0184559765 | 6 | RPI - CONS | Z2 | LS12 | ELEC | 1.3.4.10 | CONS | CONS | ZONE-3 | ELEC | LS-11 |
| CON-Z3-LS11-ELE-130 |  | Installation of Fire Alarm System including FACP, Detectors, Pull Station & Accessories | 16.8d | 2017-06-01 | 2017-06-21 | CON-Z3-LS11-ELE-100 SS, PR-Z3-GE-GE-244-0080, CON-Z3-LS11-ELE-120 SS | 51d | 0d | Electrician [78 h]; LC Crew [52 h] | 6,105.6 | 0 | 0 | 0.012921829 | 6 | RPI - CONS | Z2 | LS12 | ELEC | 1.3.4.10 | CONS | CONS | ZONE-3 | ELEC | LS-11 |
| CON-Z3-LS11-ELE-140 |  | Installation of Ultrasonic Level Sensor / Controller at LS-11 | 16.8d | 2017-06-01 | 2017-06-21 | CON-Z3-LS11-ELE-130 SS | 51d | 0d | Electrician [78 h]; LC Crew [52 h] | 6,056.55 | 0 | 0 | 0.0128180201 | 6 | RPI - CONS | Z2 | LS12 | ELEC | 1.3.4.10 | CONS | CONS | ZONE-3 | ELEC | LS-11 |

Notes:
- CON-Z3-LS11-ME-010: Expenses: (New Expense Item) 51146.4
- CON-Z3-LS11-ME-050: Expenses: (New Expense Item) 40295.4
- CON-Z3-LS11-ME-020: Expenses: (New Expense Item) 241773
- CON-Z3-LS11-ME-030: Expenses: (New Expense Item) 80590.9
- CON-Z3-LS11-ME-040: Expenses: (New Expense Item) 120886
- CON-Z3-LS11-ME-070: Expenses: (New Expense Item) 120886
- CON-Z3-LS11-ME-080: Expenses: (New Expense Item) 40295.4
- CON-Z3-LS11-EW-010: Expenses: (New Expense Item) 17441
- CON-Z3-LS11-EW-020: Expenses: (New Expense Item) 31946.8
- CON-Z3-LS11-EW-030: Expenses: (New Expense Item) 6056.55
- CON-Z3-LS11-EW-040: Expenses: (New Expense Item) 34882
- CON-Z3-LS11-EW-050: Expenses: (New Expense Item) 52323
- CON-Z3-LS11-EW-060: Expenses: (New Expense Item) 3560
- CON-Z3-LS11-ELE-010: Expenses: (New Expense Item) 17441
- CON-Z3-LS11-ELE-020: Expenses: (New Expense Item) 31946.8
- CON-Z3-LS11-ELE-030: Expenses: (New Expense Item) 129018
- CON-Z3-LS11-ELE-040: Expenses: (New Expense Item) 30342
- CON-Z3-LS11-ELE-050: Expenses: (New Expense Item) 43757.5
- CON-Z3-LS11-ELE-060: Expenses: (New Expense Item) 7986.7
- CON-Z3-LS11-ELE-070: Expenses: (New Expense Item) 3993.35
- CON-Z3-LS11-ELE-080: Expenses: (New Expense Item) 3993.35
- CON-Z3-LS11-ELE-090: Expenses: (New Expense Item) 13567
- CON-Z3-LS11-ELE-100: Expenses: (New Expense Item) 34882
- CON-Z3-LS11-ELE-110: Expenses: (New Expense Item) 8720.5
- CON-Z3-LS11-ELE-120: Expenses: (New Expense Item) 8720.5
- CON-Z3-LS11-ELE-130: Expenses: (New Expense Item) 6105.6
- CON-Z3-LS11-ELE-140: Expenses: (New Expense Item) 6056.55

| ID | WBS | Activity | Type | Duration | Start | Finish | Predecessors | Total float | Free float | Resources | Cost | Activity Wt% | Weight % | Cost Wt | RPI - PHASE | RPI - CONSTRUCTION | RPI - ZONES | RPI - BUILDINGS | RPI - TYPE OF WORK | RPI_P2 - BOQ ITEMS | RPI_P2 - CONSTRUCTION | RPI_P2 - PHASE | RPI_P2 - ZONES | RPI_P2 - DISCIPLINE / WORK TYPE | RPI_P2 - BUILDINGS | Wajid |
| --- | --- | --- | --- | --- | --- | --- | --- | --- | --- | --- | --- | --- | --- | --- | --- | --- | --- | --- | --- | --- | --- | --- | --- | --- | --- | --- |
|  | 7 | **External Works** |  |  | 2017-05-27 | 2017-08-03 |  |  |  |  |  |  |  |  |  |  |  |  |  |  |  |  |  |  |  |  |
| CON-Z3-LS11-EW-0010 |  | Cable Trench for Main feeder of LS # 11 to Transformer |  | 7.2d | 2017-05-27 | 2017-06-04 | CON-Z3-LS11-ELE-080 | 30.2d | 0d | Electrician [78 h]; LC Crew [52 h] | 7,652 | 0 | 0 | 0.0161946141 | 6 | RPI - CONS | Z2 | LS12 | CIVIL | 1.3.4.10 | CONS | CONS | ZONE-3 | CIVIL | LS-11 |  |
| CON-Z3-LS11-EW-0020 |  | Installation of Pad Mounted Transformer for Power Supply of LS-11 |  | 7.2d | 2017-06-04 | 2017-06-12 | CON-Z3-LS11-EW-0010 | 30.2d | 0d | Mechanical Technician [26 h]; Operator - Mobile Crane [26 h]; Mobile Crane ( 25-60 Ton) [28 h] | 7,652 | 0 | 0 | 0.0161946141 | 6 | RPI - CONS | Z2 | LS12 | CIVIL | 1.3.4.10 | CONS | CONS | ZONE-3 | CIVIL | LS-11 |  |
| CON-Z3-LS11-EW-0030 |  | Installation of concrete padestal for Emergency Generator |  | 8d | 2017-06-04 | 2017-06-13 | CON-Z3-LS11-EW-0020 SS | 30.2d | 0d | Steel Fixer [78 h]; Shuttering Carpenter [78 h]; Concrete Mason [78 h] | 4,214.88 | 0 | 0 | 0.0089203287 | 6 | RPI - CONS | Z2 | LS12 | CIVIL | 1.3.4.10 | CONS | CONS | ZONE-3 | CIVIL | LS-11 |  |
| CON-Z3-LS11-EW-0040 |  | Installation of Diesel Generator and Dummy Loads |  | 14.4d | 2017-06-04 | 2017-06-21 | CON-Z3-LS11-EW-0030 SS | 30.2d | 0d | Mechanical Technician [26 h]; Operator - Mobile Crane [26 h]; Mobile Crane ( 25-60 Ton) [28 h] | 21,503 | 0 | 0 | 0.0455087279 | 6 | RPI - CONS | Z2 | LS12 | CIVIL | 1.3.4.10 | CONS | CONS | ZONE-3 | CIVIL | LS-11 |  |
| CON-Z3-LS11-EW-0050 |  | Installation of Concrete Side Walks near electrical Room |  | 9.6d | 2017-06-21 | 2017-07-06 | CON-Z3-LS11-EW-0030 SS, CON-Z3-LS11-EW-0040 | 30.2d | 0d | Steel Fixer [78 h]; Shuttering Carpenter [78 h]; Concrete Mason [78 h]; Common Labor / Helper [52 h] | 5,000 | 0 | 0 | 0.0105819485 | 6 | RPI - CONS | Z2 | LS12 | CIVIL | 1.3.4.10 | CONS | CONS | ZONE-3 | CIVIL | LS-11 |  |
| CON-Z3-LS11-EW-0060 |  | Construction of Concrete Valve Box |  | 7.2d | 2017-06-21 | 2017-07-04 | CON-Z3-LS11-EW-0050 SS | 30.2d | 0d | Steel Fixer [78 h]; Shuttering Carpenter [78 h]; Concrete Mason [78 h]; Mechanical Technician [52 h] | 1,221.7 | 0 | 0 | 0.0025855933 | 6 | RPI - CONS | Z2 | LS12 | CIVIL | 1.3.4.10 | CONS | CONS | ZONE-3 | CIVIL | LS-11 |  |
| CON-Z3-LS11-EW-0070 |  | General Backfilling for LS-11 Area |  | 5.6d | 2017-07-01 | 2017-07-06 | CON-Z3-LS11-EW-0060 SS+4d | 30.2d | 0d | Common Labor / Helper [78 h]; Operator - Loader [56 h]; Driver - Dump Truck [112 h]; Operator - Bobcat [112 h]; Operator - Roller-Compactor (2~10 Ton) [56 h]; Operator - Roller (25 Ton) [56 h]; Driver - Water Tanker [56 h]; Loader [78.4 h]; Dump Truck [78.4 h]; Bobcat [78.4 h]; Roller-Compactor (2~10 Ton) [235.2 h]; Roller-Compactor (25 Ton) [78.4 h]; Water Tanker [235.2 h] | 71,446.93 | 0 | 0 | 0.1723734445 | 6 | RPI - CONS | Z2 | LS12 | CIVIL | 1.3.4.10 | CONS | CONS | ZONE-3 | CIVIL | LS-11 |  |
| CON-Z3-LS11-EW-0080 |  | Installation of curb stone |  | 6.4d | 2017-07-06 | 2017-07-15 | CON-Z3-LS11-EW-0070, CON-Z3-LS11-EW-0030 SS | 30.2d | 0d | Steel Fixer [78 h]; Shuttering Carpenter [78 h]; Concrete Mason [78 h]; Common Labor / Helper [52 h] | 13,825.56 | 0 | 0 | 0.0292602729 | 6 | RPI - CONS | Z2 | LS12 | CIVIL | 1.3.4.10 | CONS | CONS | ZONE-3 | CIVIL | LS-11 |  |
| CON-Z3-LS11-EW-0090 |  | Installation of Precast fence @ LS-11 |  | 14.4d | 2017-07-11 | 2017-07-29 | CON-Z3-LS11-EW-0080 SS+4d | 30.2d | 0d | Common Labor / Helper [78 h]; Fence Crew - Lift Station [78 h]; Operator - Mobile Crane [26 h] | 534,115.03 | 0 | 0 | 1.1635207345 | 6 | RPI - CONS | Z2 | LS12 | CIVIL | 1.3.4.10 | CONS | CONS | ZONE-3 | CIVIL | LS-11 |  |
| CON-Z3-LS11-EW-0100 |  | Installation of Steel Gate (Gate swing 4850 mm, small gate 1200mm) |  | 4d | 2017-07-25 | 2017-07-30 | CON-Z3-LS11-EW-0090 FF+1.6d | 30.2d | 0d | Specialist Works Crew [26 h]; Operator - Mobile Crane [26 h]; Forklift [28 h] | 25,384.29 | 0 | 0 | 0.0537230501 | 6 | RPI - CONS | Z2 | LS12 | CIVIL | 1.3.4.10 | CONS | CONS | ZONE-3 | CIVIL | LS-11 |  |
| CON-Z3-LS11-EW-0110 |  | Asphalt pavement at Lift Station # 11 Area |  | 3d | 2017-07-25 | 2017-07-29 | CON-Z3-LS11-EW-0090 SS, CON-Z3-LS11-EW-0070, CON-Z3-LS11-EW-0100 SS, CON-Z3-LS11-EW-0080 | 30.2d | 0d | Common Labor / Helper [52 h]; Road Works Crew [52 h]; Operator - Asphalt Paver [26 h]; Operator - Asphalt Compactor / Roller [26 h]; Operator - Roller (25 Ton) [26 h] | 66,786.48 | 0 | 0 | 0.141346219 | 6 | RPI - CONS | Z2 | LS12 | CIVIL | 1.3.4.10 | CONS | CONS | ZONE-3 | CIVIL | LS-11 |  |
| CON-Z3-LS11-EW-0120 |  | Road Marking at Lift Station # 11 Area |  | 3.2d | 2017-07-29 | 2017-08-01 | CON-Z3-LS11-EW-0110 | 30.2d | 0d | Common Labor / Helper [104 h] | 1,357.45 | 0 | 0 | 0.0028728932 | 6 | RPI - CONS | Z2 | LS12 | CIVIL | 1.3.4.10 | CONS | CONS | ZONE-3 | CIVIL | LS-11 |  |
| CON-Z3-LS11-EW-0130 |  | Traffic Sign at Lift Station # 11 Area |  | 5d | 2017-07-29 | 2017-08-03 | CON-Z3-LS11-EW-0120 SS, CON-Z3-LS11-EW-0110 | 30.2d | 0d | Shuttering Carpenter [26 h]; Common Labor / Helper [52 h] | 3,868.73 | 0 | 0 | 0.0081877404 | 6 | RPI - CONS | Z2 | LS12 | CIVIL | 1.3.4.10 | CONS | CONS | ZONE-3 | CIVIL | LS-11 |  |
|  | 8 | **Testing & Pre-Commissioning** |  |  | 2017-01-24 | 2017-08-03 |  |  |  |  |  |  |  |  |  |  |  |  |  |  |  |  |  |  |  |  |
| RPI-Z3-LS11-TC-0050 |  | Hydro Testing - Plumbing Works - LS#11 |  | 9.6d | 2017-01-24 | 2017-02-05 | CON-Z3-LS11-ME-050 | 180.6d | 150.4d | Plumber [26 h]; Common Labor / Helper [52 h]; Driver - Water Tanker [26 h] | 4,029.55 | 0 | 0 | 0.0085280982 | 6 | RPI - CONS | Z2 | LS12 | MECH | 1.3.4.10 | CONS | CONS | ZONE-3 | ELEC | LS-11 |  |
| RPI-Z3-LS11-TC-0010 |  | Testing & Balancing of HVAC System - LS#11 |  | 11.2d | 2017-06-15 | 2017-07-03 | CON-Z3-LS11-ME-070 | 57.4d | 2d | Mechanical Technician [26 h]; HVAC Crew [26 h] | 12,088.64 | 0 | 0 | 0.0255842733 | 6 | RPI - CONS | Z2 | LS12 | MECH | 1.3.4.10 | CONS | CONS | ZONE-3 | ELEC | LS-11 |  |
| RPI-Z3-LS11-TC-0020 |  | Testing & Pre-commissioning of Mechanical Works - LS#11 |  | 11.2d | 2017-06-18 | 2017-07-05 | CON-Z3-LS11-ME-080, CON-Z3-LS11-ME-060, RPI-Z3-LS11-TC-0010 SS, CON-Z3-LS11-ME-040 | 55.4d | 25.2d | Mechanical Technician [52 h]; Specialist Works Crew [26 h] | 24,177.27 | 0 | 0 | 0.0511685254 | 6 | RPI - CONS | Z2 | LS12 | MECH | 1.3.4.10 | CONS | CONS | ZONE-3 | ELEC | LS-11 |  |
| RPI-Z3-LS11-TC-0030 |  | Testing & Pre-commissioning of Electrical Works - LS#11 |  | 12.8d | 2017-06-21 | 2017-07-10 | CON-Z3-LS11-ELE-140, CON-Z3-LS11-ME-080, CON-Z3-LS11-EW-060 | 51d | 20.8d | Electrician [78 h]; LC Crew [52 h] | 11,743.5 | 0 | 0 | 0.0248538226 | 6 | RPI - CONS | Z2 | LS12 | ELEC | 1.3.4.10 | CONS | CONS | ZONE-3 | ELEC | LS-11 |  |
| RPI-Z3-LS11-TC-0060 |  | Mechanical Completion of LS#11 | milestone | 0d | 2017-08-03 | 2017-08-03 | RPI-Z3-LS11-TC-0050, RPI-Z3-LS11-TC-0010, RPI-Z3-LS11-TC-0020, CON-Z3-LS11-EW-0130 FF, RPI-Z3-LS11-TC-0030, RPI-Z3-LS11-TC-0010 FF | 30.2d | 0d |  |  | 0 | 0 | 0 | 6 | RPI - CONS | Z2 | LS12 | CIVIL | 1.3.4.10 | CONS | CONS | ZONE-3 | ELEC | LS-11 |  |
|  | 4 | **CONSTRUCTION FOR ZONE - 4** |  |  | 2016-11-01 | 2017-11-01 |  |  |  |  |  |  |  |  |  |  |  |  |  |  |  |  |  |  |  |  |
|  | 1 | **UTILITIES & SERVICES WORKS** |  |  | 2016-11-01 | 2017-11-01 |  |  |  |  |  |  |  |  |  |  |  |  |  |  |  |  |  |  |  |  |
|  | 1 | **Site Preparation, demolition and earth works** |  |  | 2016-11-01 | 2017-10-14 |  |  |  |  |  |  |  |  |  |  |  |  |  |  |  |  |  |  |  |  |
| CON-Z4-UTIL-SIT-010 |  | Site Preparation (Demolition and Removal of Unsuitable Materials) |  | 26d | 2016-11-01 | 2016-12-01 | CON-Z3-UTIL-SIT-0010 FS+21d | 41.8d | 0d | Common Labor / Helper [2704 h]; Operator - Excavator [260 h]; Operator - Loader [260 h]; Driver - Dump Truck [260 h]; Operator - Bobcat [260 h]; Operator - Roller (25 Ton) [260 h]; Excavator [260 h]; Loader [260 h]; Dump Truck [260 h]; Grader [260 h]; Bobcat [1092 h] | 1,312,198.91 |  |  |  |  |  |  |  |  | 1.3.5.10 | CONS | CONS | ZONE-4 |  |  | OK |
| CON-Z4-UTIL-SIT-10 |  | Earth Works (Cut & Fill - Leveling & Grading of un-even areas in general at Zone-3) |  | 52d | 2017-08-08 | 2017-10-14 | CON-Z4-UTIL-SIT-010 FS+210d | 41.8d |  | Excavator [2080 h]; Dump Truck [2600 h]; Loader [1040 h]; Bobcat [728 h]; Operator - JCB [2080 h]; Operator - Bobcat [3120 h]; Operator - Loader [1040 h]; Operator - Excavator [2080 h]; JCB [2080 h]; Driver - Dump Truck [2600 h] | 3,061,797.46 |  |  |  |  |  |  |  |  | 1.3.5.10 | CONS | CONS | ZONE-4 |  |  | OK |

Notes:
- CON-Z3-LS11-EW-0010: Expenses: (New Expense Item) 7652
- CON-Z3-LS11-EW-0020: Expenses: (New Expense Item) 7652
- CON-Z3-LS11-EW-0030: Expenses: (New Expense Item) 4214.88
- CON-Z3-LS11-EW-0040: Expenses: (New Expense Item) 21503
- CON-Z3-LS11-EW-0050: Expenses: (New Expense Item) 5000
- CON-Z3-LS11-EW-0060: Expenses: (New Expense Item) 1221.7
- CON-Z3-LS11-EW-0070: Expenses: (New Expense Item) 71446.9
- CON-Z3-LS11-EW-0080: Expenses: (New Expense Item) 13825.6
- CON-Z3-LS11-EW-0090: Expenses: (New Expense Item) 534115
- CON-Z3-LS11-EW-0100: Expenses: (New Expense Item) 25384.3
- CON-Z3-LS11-EW-0110: Expenses: (New Expense Item) 66786.5
- CON-Z3-LS11-EW-0120: Expenses: (New Expense Item) 1357.45
- CON-Z3-LS11-EW-0130: Expenses: (New Expense Item) 3868.73
- RPI-Z3-LS11-TC-0050: Expenses: (New Expense Item) 4029.55
- RPI-Z3-LS11-TC-0010: Expenses: (New Expense Item) 12088.6
- RPI-Z3-LS11-TC-0020: Expenses: (New Expense Item) 24177.3
- RPI-Z3-LS11-TC-0030: Expenses: (New Expense Item) 11743.5
- CON-Z4-UTIL-SIT-010: Expenses: (New Expense Item) 1312199
- CON-Z4-UTIL-SIT-10: Expenses: (New Expense Item) 3061797

| ID | WBS | Activity | Duration | Start | Finish | Predecessors | Total float | Free float | Resources | Cost | RPI_P2 - BOQ ITEMS | RPI_P2 - CONSTRUCTION | RPI_P2 - PHASE | RPI_P2 - ZONES | RPI_P2 - AREAS | RPI_P2 - UTILITY NETWORK | Activity Wt% | Weight % | Cost Wt | RPI - PHASE | RPI - CONSTRUCTION | RPI - ZONES | RPI - UTILITY NETWORKS | RPI - TYPE OF WORK |
| --- | --- | --- | --- | --- | --- | --- | --- | --- | --- | --- | --- | --- | --- | --- | --- | --- | --- | --- | --- | --- | --- | --- | --- | --- |
|  | 2 | **Potable and Fire Water System** |  | 2016-12-21 | 2017-06-01 |  |  |  |  |  |  |  |  |  |  |  |  |  |  |  |  |  |  |  |
|  | 4 | **Potable and Fire Water Lines** |  | 2016-12-21 | 2017-06-01 |  |  |  |  |  |  |  |  |  |  |  |  |  |  |  |  |  |  |  |
|  | 1 | **Potable Water Line - RTR 200mm dia at Road 2 = 53.67 Lm** |  | 2016-12-21 | 2017-01-10 |  |  |  |  |  |  |  |  |  |  |  |  |  |  |  |  |  |  |  |
| CON-Z4-UT-PW-PL-010 |  | Excavation of Trench | 0.8d | 2016-12-21 | 2016-12-21 | CON-Z3-UT-PW-PL-0070, CON-Z4-UTIL-SIT-010 | 34.4d | 0d | Common Labor / Helper [39 h]; Operator - Excavator [13 h]; Driver - Dump Truck [13 h]; Operator - JCB [13 h]; Excavator [14 h]; Dump Truck [22.4 h] | 6,019.78 | 1.3.5.20 | CONS | CONS | ZONE-4 | ROAD-2 | PW |  |  |  |  |  |  |  |  |
| CON-Z4-UT-PW-PL-020 |  | Compaction and Sand bedding | 2.4d | 2016-12-25 | 2016-12-27 | CON-Z4-UT-PW-PL-010 SS+3.2d | 98.4d | 0d | Common Labor / Helper [52 h]; Operator - Loader [13 h]; Driver - Dump Truck [13 h]; Operator - Bobcat [13 h]; Operator - JCB [13 h]; Loader [33.6 h]; Dump Truck [33.6 h]; Bobcat [33.6 h]; JCB [33.6 h] | 4,013.18 | 1.3.5.20 | CONS | CONS | ZONE-4 | ROAD-2 | PW |  |  |  |  |  |  |  |  |
| CON-Z4-UT-PW-PL-030 |  | Pipe Laying | 1.6d | 2016-12-27 | 2016-12-29 | CON-Z4-UT-PW-PL-020 SS+2.4d, PR-Z4-UT-PW-191-0080 | 98.4d | 0d | Plumber [65 h]; Common Labor / Helper [39 h]; RTR Pipe Crew [26 h]; Operator - Mobile Crane [13 h]; Driver - Flat Bed Trailer [13 h]; Mobile Crane ( 25-60 Ton) [14 h]; Flat Bed Trailer [14 h] | 12,039.55 | 1.3.5.20 | CONS | CONS | ZONE-4 | ROAD-2 | PW |  |  |  |  |  |  |  |  |
| CON-Z4-UT-PW-PL-040 |  | Installation of Thurst Block | 1d | 2017-01-01 | 2017-01-02 | CON-Z4-UT-PW-PL-030 SS+4d | 98.4d | 0d | Steel Fixer [26 h]; Shuttering Carpenter [52 h]; Concrete Mason [52 h]; Common Labor / Helper [52 h]; Driver - Conc. Transit Mixers [26 h]; Operator - Concrete Pump [26 h]; Concrete Transit Mixers [28 h]; Concrete Pump [28 h] | 4,013.18 | 1.3.5.20 | CONS | CONS | ZONE-4 | ROAD-2 | PW |  |  |  |  |  |  |  |  |
| CON-Z4-UT-PW-PL-050 |  | Backfilling | 4d | 2017-01-02 | 2017-01-07 | CON-Z4-UT-PW-PL-030, CON-Z4-UT-PW-PL-040 | 98.4d | 0d | Common Labor / Helper [52 h]; Operator - Loader [13 h]; Driver - Dump Truck [13 h]; Operator - Bobcat [13 h]; Operator - Asphalt Compactor / Roller [13 h]; Operator - Roller-Compactor (2~10 Ton) [13 h]; Driver - Water Tanker [13 h]; Operator - JCB [13 h]; Loader [14 h]; Dump Truck [14 h]; Bobcat [14 h]; Roller-Compactor (2~10 Ton) [14 h]; Roller-Compactor (25 Ton) [14 h]; Water Tanker [14 h] | 6,019.78 | 1.3.5.20 | CONS | CONS | ZONE-4 | ROAD-2 | PW |  |  |  |  |  |  |  |  |
| CON-Z4-UT-PW-PL-110 |  | Testing and Precommissioning | 3.2d | 2017-01-07 | 2017-01-10 | CON-Z4-UT-PW-PL-050 | 98.4d | 64d | Plumber [52 h]; Common Labor / Helper [52 h]; RTR Pipe Crew [52 h]; Driver - Water Tanker [26 h]; Water Tanker [28 h] | 8,026.37 | 1.3.5.20 | CONS | CONS | ZONE-4 | ROAD-2 | PW |  |  |  |  |  |  |  |  |
|  | 2 | **Potable Water Line - RTR 200mm dia at Road 3 = 2341.5 Lm** |  | 2016-12-27 | 2017-04-23 |  |  |  |  |  |  |  |  |  |  |  |  |  |  |  |  |  |  |  |
| CON-Z4-UT-PW-PL-060 |  | Excavation of Trench | 16d | 2016-12-27 | 2017-01-15 | CON-Z4-UT-PW-PL-010 FS+5d | 34.4d | 0d | Common Labor / Helper [507 h]; Operator - Excavator [338 h]; Driver - Dump Truck [507 h]; Operator - JCB [507 h]; Excavator [364 h]; Dump Truck [546 h]; JCB [364 h] | 24,079.11 | 1.3.5.20 | CONS | CONS | ZONE-4 | ROAD-3 | PW |  |  |  |  |  |  |  |  |
| CON-Z4-UT-PW-PL-070 |  | Compaction and Sand bedding | 24d | 2017-01-01 | 2017-01-28 | CON-Z4-UT-PW-PL-060 SS+3.2d | 34.4d | 0d | Common Labor / Helper [1690 h]; Operator - Loader [338 h]; Driver - Dump Truck [507 h]; Operator - Bobcat [507 h]; Operator - JCB [507 h]; Loader [364 h]; Dump Truck [546 h]; Bobcat [546 h]; JCB [364 h] | 16,052.74 | 1.3.5.20 | CONS | CONS | ZONE-4 | ROAD-3 | PW |  |  |  |  |  |  |  |  |
| CON-Z4-UT-PW-PL-080 |  | Pipe Laying | 46.4d | 2017-01-03 | 2017-02-26 | CON-Z4-UT-PW-PL-070 SS+2.4d | 34.4d | 0d | Plumber [2535 h]; Common Labor / Helper [1014 h]; RTR Pipe Crew [1690 h]; Operator - Mobile Crane [169 h]; Driver - Flat Bed Trailer [169 h]; Mobile Crane ( 25-60 Ton) [182 h]; Flat Bed Trailer [182 h] | 48,158.21 | 1.3.5.20 | CONS | CONS | ZONE-4 | ROAD-3 | PW |  |  |  |  |  |  |  |  |
| CON-Z4-UT-PW-PL-090 |  | Instalaltion of Thurst Block | 15d | 2017-01-08 | 2017-01-25 | CON-Z4-UT-PW-PL-080 SS+4d | 61.8d | 27.4d | Steel Fixer [26 h]; Shuttering Carpenter [52 h]; Concrete Mason [52 h]; Common Labor / Helper [52 h]; Driver - Conc. Transit Mixers [26 h]; Operator - Concrete Pump [26 h] | 16,052.74 | 1.3.5.20 | CONS | CONS | ZONE-4 | ROAD-3 | PW |  |  |  |  |  |  |  |  |
| CON-Z4-UT-PW-PL-100 |  | Backfilling | 24d | 2017-02-26 | 2017-03-26 | CON-Z4-UT-PW-PL-090, CON-Z4-UT-PW-PL-080 | 34.4d | 0d | Common Labor / Helper [8580 h]; Operator - Loader [429 h]; Driver - Dump Truck [858 h]; Operator - Bobcat [429 h]; Operator - Asphalt Compactor / Roller [429 h]; Operator - Roller-Compactor (2~10 Ton) [429 h]; Driver - Water Tanker [429 h]; Operator - JCB [858 h]; Loader [462 h]; Dump Truck [462 h]; Bobcat [462 h]; Roller-Compactor (2~10 Ton) [462 h]; Plate Compactor [462 h]; Vibrators [462 h]; Water Tanker [462 h]; JCB [462 h] | 24,079.11 | 1.3.5.20 | CONS | CONS | ZONE-4 | ROAD-3 | PW |  |  |  |  |  |  |  |  |
| CON-Z4-UT-PW-PL-120 |  | Testing and Precommissioning | 24d | 2017-03-26 | 2017-04-23 | CON-Z4-UT-PW-PL-100, CON-Z4-UT-PW-PL-110 | 34.4d | 0d | Plumber [52 h]; Common Labor / Helper [52 h]; RTR Pipe Crew [52 h]; Driver - Water Tanker [26 h]; Water Tanker [28 h] | 32,105.48 | 1.3.5.20 | CONS | CONS | ZONE-4 | ROAD-3 | PW |  |  |  |  |  |  |  |  |
|  | 13 | **Fire Hydrants and Accessories** |  | 2017-05-15 | 2017-06-01 |  |  |  |  |  |  |  |  |  |  |  |  |  |  |  |  |  |  |  |
| CON-Z4-UT-PW-FH-010 |  | Insttaltion of Fire Hydrants including Break Check Values and Accessories | 12d | 2017-05-15 | 2017-05-29 | CON-Z4-UT-PW-PL-120 FS+19d, PR-Z4-UT-PW-193-0080, CON-Z4-UT-PW-PL-080 | 34.4d | 0d | Plumber [52 h]; Common Labor / Helper [52 h] | 24,079.11 | 1.3.5.20 | CONS | CONS | ZONE-4 |  | PW |  |  |  |  |  |  |  |  |
| CON-Z4-UT-PW-FH-020 |  | Instalaltion of Gate Valves Direct Burried with Extension Spindle & Surface Box | 12d | 2017-05-18 | 2017-06-01 | PR-Z4-UT-PW-194-0080, CON-Z4-UT-PW-FH-010 SS+2.4d | 34.4d | 0d | Common Labor / Helper [26 h]; RTR Pipe Crew [26 h] | 20,065.92 | 1.3.5.20 | CONS | CONS | ZONE-4 |  | PW |  |  |  |  |  |  |  |  |
| CON-Z4-UT-PW-FH-030 |  | Instalaltion of Metallic Flanges, Pipe & Fittings for Fire Hydrants | 12d | 2017-05-18 | 2017-06-01 | PR-Z4-UT-PW-195-0080, CON-Z4-UT-PW-FH-010 SS+2.4d | 34.4d | 0d | Plumber [52 h]; Common Labor / Helper [52 h] | 20,065.92 | 1.3.5.20 | CONS | CONS | ZONE-4 |  | PW |  |  |  |  |  |  |  |  |
| CON-Z4-UT-PW-FH-040 |  | Installation of Guard Post for Fire Hydrants | 8d | 2017-05-21 | 2017-05-30 | PR-Z4-UT-PW-196-0080, CON-Z4-UT-PW-FH-030 SS+2.4d, CON-Z4-UT-PW-FH-020 SS+2.4d, CON-Z3-UT-PW-FH-040 SS | 34.4d | 0d | Common Labor / Helper [78 h] | 16,052.74 | 1.3.5.20 | CONS | CONS | ZONE-4 |  | PW |  |  |  |  |  |  |  |  |
|  | 3 | **Potable and Fire Water Chambers** |  | 2017-03-26 | 2017-06-01 |  |  |  |  |  |  |  |  |  |  |  |  |  |  |  |  |  |  |  |
|  | 2 | **Chamber - VB Type D at Road E** |  | 2017-03-26 | 2017-05-25 |  |  |  |  |  |  |  |  |  |  |  |  |  |  |  |  |  |  |  |
| CON-Z4-UT-PW-VC-0010 |  | Excavation and Compaction | 1.6d | 2017-03-26 | 2017-03-28 | CON-Z4-UT-PW-PL-060 FS+60d | 61.8d | 0d | Operator - Excavator [26 h] | 3,009.89 | 1.3.5.20 | CONS | CONS | ZONE-4 | ROAD-E | PW | 0 | 0 | 0.0030836221 | 6 | RPI - CONS | Z2 | PW | MECH |
| CON-Z4-UT-PW-VC-0020 |  | Lean concrete | 0.8d | 2017-03-28 | 2017-03-29 | CON-Z4-UT-PW-VC-0010 | 61.8d | 0d | Concrete Mason [52 h]; Driver - Conc. Transit Mixers [26 h]; Operator - Concrete Pump [26 h] | 1,805.93 | 1.3.5.20 | CONS | CONS | ZONE-4 | ROAD-E | PW | 0 | 0 | 0.0003088871 | 6 | RPI - CONS | Z2 | PW | MECH |
| CON-Z4-UT-PW-VC-0050 |  | Formwork for Base Slab | 0.8d | 2017-03-29 | 2017-03-29 | CON-Z4-UT-PW-VC-0020 | 61.8d | 0d | Shuttering Carpenter [78 h]; Common Labor / Helper [52 h] | 3,009.89 | 1.3.5.20 | CONS | CONS | ZONE-4 | ROAD-E | PW | 0 | 0 | 0.000308358 | 6 | RPI - CONS | Z2 | PW | MECH |
| CON-Z4-UT-PW-VC-0030 |  | Fabrication & installation of Rebar for Base Slab | 4d | 2017-03-30 | 2017-04-03 | CON-Z4-UT-PW-VC-0050, PR-Z3-CW-CW-25-0080 | 61.8d | 0d | Steel Fixer [78 h] | 3,009.89 | 1.3.5.20 | CONS | CONS | ZONE-4 | ROAD-E | PW | 0 | 0 | 0.0015418111 | 6 | RPI - CONS | Z2 | PW | MECH |
| CON-Z4-UT-PW-VC-0040 |  | Fabrication & installation of Rebar for Side walls | 4d | 2017-04-04 | 2017-04-08 | CON-Z4-UT-PW-VC-0030 | 61.8d | 0d | Steel Fixer [78 h] | 3,009.89 | 1.3.5.20 | CONS | CONS | ZONE-4 | ROAD-E | PW | 0 | 0 | 0.0030836221 | 6 | RPI - CONS | Z2 | PW | MECH |
| CON-Z4-UT-PW-VC-0070 |  | Formwork for side walls | 4d | 2017-04-04 | 2017-04-09 | CON-Z4-UT-PW-VC-0040 SS+0.8d | 61.8d | 0d | Shuttering Carpenter [78 h]; Common Labor / Helper [26 h]; Scaffolder [52 h] | 6,019.78 | 1.3.5.20 | CONS | CONS | ZONE-4 | ROAD-E | PW | 0 | 0 | 0.0015418111 | 6 | RPI - CONS | Z2 | PW | MECH |
| CON-Z4-UT-PW-VC-0060 |  | Concrete pouring for base slab | 0.8d | 2017-04-09 | 2017-04-10 | CON-Z4-UT-PW-VC-0070 | 61.8d | 0d | Concrete Mason [78 h]; Common Labor / Helper [26 h]; Finishing Work Crew [52 h]; Driver - Conc. Transit Mixers [26 h]; Operator - Concrete Pump [26 h] | 3,009.89 | 1.3.5.20 | CONS | CONS | ZONE-4 | ROAD-E | PW | 0 | 0 | 0.0015418111 | 6 | RPI - CONS | Z2 | PW | MECH |
| CON-Z4-UT-PW-VC-0080 |  | Concrete pouring for Side Wall | 0.8d | 2017-04-10 | 2017-04-11 | CON-Z4-UT-PW-VC-0060 | 61.8d | 0d | Concrete Mason [78 h]; Common Labor / Helper [26 h]; Finishing Work Crew [52 h]; Driver - Conc. Transit Mixers [26 h]; Operator - Concrete Pump [26 h] | 6,019.78 | 1.3.5.20 | CONS | CONS | ZONE-4 | ROAD-E | PW | 0 | 0 | 0.0040086961 | 6 | RPI - CONS | Z2 | PW | MECH |
| CON-Z4-UT-PW-VC-0090 |  | Formwork removal and concrete patching | 1.6d | 2017-04-11 | 2017-04-12 | CON-Z4-UT-PW-VC-0080 | 61.8d | 0d | Shuttering Carpenter [78 h]; Scaffolder [26 h]; Finishing Work Crew [52 h] | 1,203.96 | 1.3.5.20 | CONS | CONS | ZONE-4 | ROAD-E | PW | 0 | 0 | 0.0015418111 | 6 | RPI - CONS | Z2 | PW | MECH |
| CON-Z4-UT-PW-VC-0110 |  | Concrete Supports | 0.8d | 2017-04-13 | 2017-04-13 | CON-Z4-UT-PW-VC-0090 | 61.8d | 0d | Shuttering Carpenter [26 h]; Concrete Mason [26 h]; Common Labor / Helper [26 h] | 1,805.93 | 1.3.5.20 | CONS | CONS | ZONE-4 | ROAD-E | PW | 0 | 0 | 0.000616716 | 6 | RPI - CONS | Z2 | PW | MECH |
| CON-Z4-UT-PW-VC-0100 |  | Installation of Pipe Connections / Closing of Openings | 3.2d | 2017-04-13 | 2017-04-17 | CON-Z4-UT-PW-VC-0110, PR-Z4-UT-PW-199-0080 | 61.8d | 0d | Shuttering Carpenter [26 h]; Concrete Mason [26 h]; Plumber [26 h]; Common Labor / Helper [26 h] | 6,019.78 | 1.3.5.20 | CONS | CONS | ZONE-4 | ROAD-E | PW | 0 | 0 | 0.0055505071 | 6 | RPI - CONS | Z2 | PW | MECH |
| CON-Z4-UT-PW-VC-5720 |  | Instalaltion of Dismantling Joints | 3d | 2017-04-13 | 2017-04-17 | CON-Z4-UT-PW-VC-0100 SS, PR-Z4-UT-PW-197-0080 | 61.8d | 0d | Common Labor / Helper [26 h]; RTR Pipe Crew [26 h] | 3,009.89 | 1.3.5.20 | CONS | CONS | ZONE-4 | ROAD-E | PW | 0 | 0 | 0.0037003381 | 6 | RPI - CONS | Z2 | PW | MECH |
| CON-Z4-UT-PW-VC-5730 |  | Instalaltion of Gate Valves and Pressure Releasing Valves | 2.4d | 2017-04-16 | 2017-04-19 | PR-Z4-UT-PW-198-0080, PR-Z4-UT-PW-194-0080, CON-Z4-UT-PW-VC-5720 SS+2d | 61.8d | 27.4d | Common Labor / Helper [26 h]; RTR Pipe Crew [26 h] | 9,029.67 | 1.3.5.20 | CONS | CONS | ZONE-4 | ROAD-E | PW |  |  |  |  |  |  |  |  |
| CON-Z4-UT-PW-VC-0120 |  | Damp Proof Coating | 0.8d | 2017-04-18 | 2017-04-18 | CON-Z4-UT-PW-VC-0090, CON-Z4-UT-PW-VC-0100 | 62.2d | 0d | Painter [52 h]; Water Proofing Crew [52 h] | 1,203.96 | 1.3.5.20 | CONS | CONS | ZONE-4 | ROAD-E | PW | 0 | 0 | 0.0015418111 | 6 | RPI - CONS | Z2 | PW | MECH |
| CON-Z4-UT-PW-VC-0130 |  | Backfilling & Compaction | 4d | 2017-04-18 | 2017-04-23 | CON-Z4-UT-PW-PL-100, CON-Z4-UT-PW-VC-0120 | 62.2d | 27.8d | Common Labor / Helper [52 h]; Driver - Dump Truck [26 h]; Operator - Bobcat [26 h]; Operator - Roller-Compactor (2~10 Ton) [26 h]; Driver - Water Tanker [26 h]; Operator - JCB [26 h]; Bobcat [28 h]; Roller-Compactor (2~10 Ton) [28 h]; Roller-Compactor (25 Ton) [28 h]; Water Tanker [28 h] | 3,009.89 | 1.3.5.20 | CONS | CONS | ZONE-4 | ROAD-E | PW | 0 | 0 | 0.0037003381 | 6 | RPI - CONS | Z2 | PW | MECH |
| CON-Z4-UT-PW-VC-5740 |  | Installation of Roof Slab, Manhole Cover, Accessories & Finishes | 4d | 2017-05-21 | 2017-05-25 | CON-Z4-UT-PW-VC-5730, CON-Z4-UT-PW-FH-040 SS, CON-Z4-UT-PW-VC-0130 SS | 34.4d | 1.6d | Common Labor / Helper [52 h]; Finishing Work Crew [52 h] | 6,019.78 | 1.3.5.20 | CONS | CONS | ZONE-4 | ROAD-E | PW |  |  |  |  |  |  |  |  |

Notes:
- CON-Z4-UT-PW-PL-010: Expenses: (New Expense Item) 6019.78
- CON-Z4-UT-PW-PL-020: Expenses: (New Expense Item) 4013.18
- CON-Z4-UT-PW-PL-030: Expenses: (New Expense Item) 12039.5
- CON-Z4-UT-PW-PL-040: Expenses: (New Expense Item) 4013.18
- CON-Z4-UT-PW-PL-050: Expenses: (New Expense Item) 6019.78
- CON-Z4-UT-PW-PL-110: Expenses: (New Expense Item) 8026.37
- CON-Z4-UT-PW-PL-060: Expenses: (New Expense Item) 24079.1
- CON-Z4-UT-PW-PL-070: Expenses: (New Expense Item) 16052.7
- CON-Z4-UT-PW-PL-080: Expenses: (New Expense Item) 48158.2
- CON-Z4-UT-PW-PL-090: Expenses: (New Expense Item) 16052.7
- CON-Z4-UT-PW-PL-100: Expenses: (New Expense Item) 24079.1
- CON-Z4-UT-PW-PL-120: Expenses: (New Expense Item) 32105.5
- CON-Z4-UT-PW-FH-010: Expenses: (New Expense Item) 24079.1
- CON-Z4-UT-PW-FH-020: Expenses: (New Expense Item) 20065.9
- CON-Z4-UT-PW-FH-030: Expenses: (New Expense Item) 20065.9
- CON-Z4-UT-PW-FH-040: Expenses: (New Expense Item) 16052.7
- CON-Z4-UT-PW-VC-0010: Expenses: (New Expense Item) 3009.89
- CON-Z4-UT-PW-VC-0020: Expenses: (New Expense Item) 1805.93
- CON-Z4-UT-PW-VC-0050: Expenses: (New Expense Item) 3009.89
- CON-Z4-UT-PW-VC-0030: Expenses: (New Expense Item) 3009.89
- CON-Z4-UT-PW-VC-0040: Expenses: (New Expense Item) 3009.89
- CON-Z4-UT-PW-VC-0070: Expenses: (New Expense Item) 6019.78
- CON-Z4-UT-PW-VC-0060: Expenses: (New Expense Item) 3009.89
- CON-Z4-UT-PW-VC-0080: Expenses: (New Expense Item) 6019.78
- CON-Z4-UT-PW-VC-0090: Expenses: (New Expense Item) 1203.96
- CON-Z4-UT-PW-VC-0110: Expenses: (New Expense Item) 1805.93
- CON-Z4-UT-PW-VC-0100: Expenses: (New Expense Item) 6019.78
- CON-Z4-UT-PW-VC-5720: Expenses: (New Expense Item) 3009.89
- CON-Z4-UT-PW-VC-5730: Expenses: (New Expense Item) 9029.67
- CON-Z4-UT-PW-VC-0120: Expenses: (New Expense Item) 1203.96
- CON-Z4-UT-PW-VC-0130: Expenses: (New Expense Item) 3009.89
- CON-Z4-UT-PW-VC-5740: Expenses: (New Expense Item) 6019.78

| ID | WBS | Activity | Duration | Start | Finish | Predecessors | Total float | Free float | Resources | Cost | Activity Wt% | Weight % | Cost Wt | RPI - PHASE | RPI - CONSTRUCTION | RPI - ZONES | RPI - UTILITY NETWORKS | RPI - TYPE OF WORK | RPI_P2 - BOQ ITEMS | RPI_P2 - CONSTRUCTION | RPI_P2 - PHASE | RPI_P2 - ZONES | RPI_P2 - AREAS | RPI_P2 - UTILITY NETWORK |
| --- | --- | --- | --- | --- | --- | --- | --- | --- | --- | --- | --- | --- | --- | --- | --- | --- | --- | --- | --- | --- | --- | --- | --- | --- |
|  | 1 | **Chamber - New VB Type B1 at Road 3** |  | 2017-03-28 | 2017-06-01 |  |  |  |  |  |  |  |  |  |  |  |  |  |  |  |  |  |  |  |
| CON-Z4-UT-PW-VC-0150 |  | Excavation and Compaction | 1.6d | 2017-03-28 | 2017-03-29 | CON-Z4-UT-PW-PL-060, CON-Z4-UT-PW-VC-0010 | 64.2d | 0d | Operator - Excavator [26 h] | 3,009.89 | 0 | 0 | 0.0030836221 | 6 | RPI - CONS | Z2 | PW | MECH | 1.3.5.20 | CONS | CONS | ZONE-4 | ROAD-3 | PW |
| CON-Z4-UT-PW-VC-0160 |  | Lean concrete | 0.8d | 2017-03-30 | 2017-03-30 | CON-Z4-UT-PW-VC-0150 | 64.2d | 0d | Concrete Mason [52 h]; Driver - Conc. Transit Mixers [26 h]; Operator - Concrete Pump [26 h] | 1,805.93 | 0 | 0 | 0.0003088871 | 6 | RPI - CONS | Z2 | PW | MECH | 1.3.5.20 | CONS | CONS | ZONE-4 | ROAD-3 | PW |
| CON-Z4-UT-PW-VC-0190 |  | Formwork for Base Slab | 0.8d | 2017-03-30 | 2017-04-01 | CON-Z4-UT-PW-VC-0160 | 64.2d | 0d | Shuttering Carpenter [78 h]; Common Labor / Helper [52 h] | 3,009.89 | 0 | 0 | 0.000308358 | 6 | RPI - CONS | Z2 | PW | MECH | 1.3.5.20 | CONS | CONS | ZONE-4 | ROAD-3 | PW |
| CON-Z4-UT-PW-VC-0170 |  | Fabrication & installation of Rebar for Base Slab | 4d | 2017-04-01 | 2017-04-05 | CON-Z4-UT-PW-VC-0190 | 64.2d | 0d | Steel Fixer [78 h] | 3,009.89 | 0 | 0 | 0.0015418111 | 6 | RPI - CONS | Z2 | PW | MECH | 1.3.5.20 | CONS | CONS | ZONE-4 | ROAD-3 | PW |
| CON-Z4-UT-PW-VC-0180 |  | Fabrication & installation of Rebar for Side walls | 4d | 2017-04-05 | 2017-04-10 | CON-Z4-UT-PW-VC-0170 | 64.2d | 0d | Steel Fixer [78 h] | 3,009.89 | 0 | 0 | 0.0030836221 | 6 | RPI - CONS | Z2 | PW | MECH | 1.3.5.20 | CONS | CONS | ZONE-4 | ROAD-3 | PW |
| CON-Z4-UT-PW-VC-0210 |  | Formwork for side walls | 4d | 2017-04-06 | 2017-04-11 | CON-Z4-UT-PW-VC-0180 SS+0.8d | 64.2d | 0d | Shuttering Carpenter [78 h]; Common Labor / Helper [26 h]; Scaffolder [52 h] | 6,019.78 | 0 | 0 | 0.0015418111 | 6 | RPI - CONS | Z2 | PW | MECH | 1.3.5.20 | CONS | CONS | ZONE-4 | ROAD-3 | PW |
| CON-Z4-UT-PW-VC-0200 |  | Concrete pouring for base slab | 0.8d | 2017-04-11 | 2017-04-12 | CON-Z4-UT-PW-VC-0210 | 64.2d | 0d | Concrete Mason [78 h]; Common Labor / Helper [26 h]; Finishing Work Crew [52 h]; Driver - Conc. Transit Mixers [26 h]; Operator - Concrete Pump [26 h] | 3,009.89 | 0 | 0 | 0.0015418111 | 6 | RPI - CONS | Z2 | PW | MECH | 1.3.5.20 | CONS | CONS | ZONE-4 | ROAD-3 | PW |
| CON-Z4-UT-PW-VC-0220 |  | Concrete pouring for Side Wall | 0.8d | 2017-04-12 | 2017-04-12 | CON-Z4-UT-PW-VC-0200 | 64.2d | 0d | Concrete Mason [78 h]; Common Labor / Helper [26 h]; Finishing Work Crew [52 h]; Driver - Conc. Transit Mixers [26 h]; Operator - Concrete Pump [26 h] | 6,019.78 | 0 | 0 | 0.0040086961 | 6 | RPI - CONS | Z2 | PW | MECH | 1.3.5.20 | CONS | CONS | ZONE-4 | ROAD-3 | PW |
| CON-Z4-UT-PW-VC-0230 |  | Formwork removal and concrete patching | 1.6d | 2017-04-13 | 2017-04-15 | CON-Z4-UT-PW-VC-0220 | 64.2d | 0d | Shuttering Carpenter [78 h]; Scaffolder [26 h]; Finishing Work Crew [52 h] | 1,203.96 | 0 | 0 | 0.0015418111 | 6 | RPI - CONS | Z2 | PW | MECH | 1.3.5.20 | CONS | CONS | ZONE-4 | ROAD-3 | PW |
| CON-Z4-UT-PW-VC-0250 |  | Concrete Supports | 0.8d | 2017-04-15 | 2017-04-16 | CON-Z4-UT-PW-VC-0230 | 64.2d | 0d | Shuttering Carpenter [26 h]; Concrete Mason [26 h]; Common Labor / Helper [26 h] | 1,805.93 | 0 | 0 | 0.000616716 | 6 | RPI - CONS | Z2 | PW | MECH | 1.3.5.20 | CONS | CONS | ZONE-4 | ROAD-3 | PW |
| CON-Z4-UT-PW-VC-0240 |  | Installation of Pipe Connections / Closing of Openings | 3.2d | 2017-04-16 | 2017-04-19 | CON-Z4-UT-PW-VC-0250 | 64.2d | 0d | Shuttering Carpenter [26 h]; Concrete Mason [26 h]; Plumber [26 h]; Common Labor / Helper [26 h] | 6,019.78 | 0 | 0 | 0.0055505071 | 6 | RPI - CONS | Z2 | PW | MECH | 1.3.5.20 | CONS | CONS | ZONE-4 | ROAD-3 | PW |
| CON-Z4-UT-PW-VC-5750 |  | Instalaltion of Dismantling Joints | 3d | 2017-04-16 | 2017-04-19 | CON-Z4-UT-PW-VC-0240 SS | 64.2d | 0d | Common Labor / Helper [26 h]; RTR Pipe Crew [26 h] | 3,009.89 | 0 | 0 | 0.0037003381 | 6 | RPI - CONS | Z2 | PW | MECH | 1.3.5.20 | CONS | CONS | ZONE-4 | ROAD-3 | PW |
| CON-Z4-UT-PW-VC-5760 |  | Instalaltion of Gate Valves and Pressure Releasing Valves | 2.4d | 2017-04-18 | 2017-04-20 | CON-Z4-UT-PW-VC-5750 SS+2d, PR-Z4-UT-PW-194-0080 | 64.2d | 31.4d | Common Labor / Helper [26 h]; RTR Pipe Crew [26 h] | 9,029.67 |  |  |  |  |  |  |  |  | 1.3.5.20 | CONS | CONS | ZONE-4 | ROAD-3 | PW |
| CON-Z4-UT-PW-VC-0260 |  | Damp Proof Coating | 0.8d | 2017-04-19 | 2017-04-20 | CON-Z4-UT-PW-VC-0230, CON-Z4-UT-PW-VC-0240 | 64.6d | 0d | Painter [52 h]; Water Proofing Crew [52 h] | 1,203.96 | 0 | 0 | 0.0015418111 | 6 | RPI - CONS | Z2 | PW | MECH | 1.3.5.20 | CONS | CONS | ZONE-4 | ROAD-3 | PW |
| CON-Z4-UT-PW-VC-0270 |  | Backfilling & Compaction | 4d | 2017-04-20 | 2017-04-25 | CON-Z4-UT-PW-VC-0260 | 64.6d | 31.8d | Common Labor / Helper [52 h]; Driver - Dump Truck [26 h]; Operator - Bobcat [26 h]; Operator - Roller-Compactor (2~10 Ton) [26 h]; Driver - Water Tanker [26 h]; Operator - JCB [26 h]; Bobcat [28 h]; Roller-Compactor (2~10 Ton) [28 h]; Roller-Compactor (25 Ton) [28 h]; Water Tanker [28 h] | 3,009.89 | 0 | 0 | 0.0037003381 | 6 | RPI - CONS | Z2 | PW | MECH | 1.3.5.20 | CONS | CONS | ZONE-4 | ROAD-3 | PW |
| CON-Z4-UT-PW-VC-5770 |  | Installation of Roof Slab, Manhole Cover, Accessories & Finishes | 4d | 2017-05-28 | 2017-06-01 | CON-Z3-UT-PW-VC-5710 SS, CON-Z4-UT-PW-VC-5740, CON-Z4-UT-PW-VC-0270 SS, CON-Z4-UT-PW-VC-5760 | 32.8d | 2d | Common Labor / Helper [52 h]; Finishing Work Crew [52 h] | 6,019.78 |  |  |  |  |  |  |  |  | 1.3.5.20 | CONS | CONS | ZONE-4 | ROAD-3 | PW |
|  | 3 | **Seawater System** |  | 2017-04-12 | 2017-08-02 |  |  |  |  |  |  |  |  |  |  |  |  |  |  |  |  |  |  |  |
|  | 8 | **Sea Water Lines** |  | 2017-04-12 | 2017-06-10 |  |  |  |  |  |  |  |  |  |  |  |  |  |  |  |  |  |  |  |
|  | 4 | **Sea Water Line - RTR 300mm dia at Road 3 = 358 Lm (1st Line)** |  | 2017-04-12 | 2017-05-31 |  |  |  |  |  |  |  |  |  |  |  |  |  |  |  |  |  |  |  |
| CON-Z4-UT-SEA-PL-010 |  | Excavation of Trench (138 Lm) | 1.6d | 2017-04-12 | 2017-04-13 | CON-Z3-UT-SEA-PL-360 FS+100d | 78d | 0d | Common Labor / Helper [39 h]; Operator - Excavator [13 h]; Driver - Dump Truck [13 h]; Operator - JCB [13 h]; Excavator [14 h]; Dump Truck [14 h] | 4,002.89 |  |  |  |  |  |  |  |  | 1.3.5.30 | CONS | CONS | ZONE-4 | ROAD-3 | SEA-W |
| CON-Z4-UT-SEA-PL-020 |  | Compaction and Sand bedding (138 Lm) | 2.4d | 2017-04-16 | 2017-04-18 | CON-Z4-UT-SEA-PL-010 SS+3.2d | 82.2d | 0d | Common Labor / Helper [52 h]; Operator - Loader [13 h]; Driver - Dump Truck [13 h]; Operator - Bobcat [13 h]; Operator - JCB [13 h]; Loader [14 h]; Dump Truck [14 h]; Bobcat [14 h]; JCB [14 h] | 2,668.59 |  |  |  |  |  |  |  |  | 1.3.5.30 | CONS | CONS | ZONE-4 | ROAD-3 | SEA-W |
| CON-Z4-UT-SEA-PL-030 |  | Pipe Laying (138 Lm) | 4d | 2017-04-18 | 2017-04-23 | CON-Z4-UT-SEA-PL-020 SS+2.4d, PR-Z4-UT-SE-201-0080 | 82.2d | 0d | Plumber [65 h]; Common Labor / Helper [39 h]; RTR Pipe Crew [26 h]; Operator - Mobile Crane [13 h]; Driver - Flat Bed Trailer [13 h]; Mobile Crane ( 25-60 Ton) [14 h]; Flat Bed Trailer [14 h] | 8,005.78 |  |  |  |  |  |  |  |  | 1.3.5.30 | CONS | CONS | ZONE-4 | ROAD-3 | SEA-W |
| CON-Z4-UT-SEA-PL-040 |  | Installation of Thurst Block | 4d | 2017-04-23 | 2017-04-27 | CON-Z4-UT-SEA-PL-030 SS+4d | 82.2d | 0d | Steel Fixer [26 h]; Shuttering Carpenter [52 h]; Concrete Mason [52 h]; Common Labor / Helper [52 h]; Driver - Conc. Transit Mixers [26 h]; Operator - Concrete Pump [26 h]; Concrete Transit Mixers [28 h]; Concrete Pump [28 h] | 2,668.59 |  |  |  |  |  |  |  |  | 1.3.5.30 | CONS | CONS | ZONE-4 | ROAD-3 | SEA-W |
| CON-Z4-UT-SEA-PL-050 |  | Backfilling (358 Lm) | 12d | 2017-04-27 | 2017-05-11 | CON-Z4-UT-SEA-PL-030, CON-Z4-UT-SEA-PL-040 | 82.2d | 8.8d | Common Labor / Helper [52 h]; Operator - Loader [13 h]; Driver - Dump Truck [13 h]; Operator - Bobcat [13 h]; Operator - Asphalt Compactor / Roller [13 h]; Operator - Roller-Compactor (2~10 Ton) [13 h]; Driver - Water Tanker [13 h]; Operator - JCB [13 h]; Loader [14 h]; Dump Truck [14 h]; Bobcat [14 h]; Roller-Compactor (2~10 Ton) [14 h]; Plate Compactor [14 h]; Vibrators [14 h]; Water Tanker [14 h]; JCB [14 h] | 4,002.89 |  |  |  |  |  |  |  |  | 1.3.5.30 | CONS | CONS | ZONE-4 | ROAD-3 | SEA-W |
| CON-Z4-UT-SEA-PL-160 |  | Testing and Precommissioning (358 Lm) | 8d | 2017-05-22 | 2017-05-31 | CON-Z4-UT-SEA-PL-050, CON-Z3-UT-SEA-PL-410 SS | 73.4d | 0d | Plumber [52 h]; Common Labor / Helper [52 h]; RTR Pipe Crew [52 h]; Driver - Water Tanker [26 h]; Water Tanker [28 h] | 5,337.19 |  |  |  |  |  |  |  |  | 1.3.5.30 | CONS | CONS | ZONE-4 | ROAD-3 | SEA-W |

Notes:
- CON-Z4-UT-PW-VC-0150: Expenses: (New Expense Item) 3009.89
- CON-Z4-UT-PW-VC-0160: Expenses: (New Expense Item) 1805.93
- CON-Z4-UT-PW-VC-0190: Expenses: (New Expense Item) 3009.89
- CON-Z4-UT-PW-VC-0170: Expenses: (New Expense Item) 3009.89
- CON-Z4-UT-PW-VC-0180: Expenses: (New Expense Item) 3009.89
- CON-Z4-UT-PW-VC-0210: Expenses: (New Expense Item) 6019.78
- CON-Z4-UT-PW-VC-0200: Expenses: (New Expense Item) 3009.89
- CON-Z4-UT-PW-VC-0220: Expenses: (New Expense Item) 6019.78
- CON-Z4-UT-PW-VC-0230: Expenses: (New Expense Item) 1203.96
- CON-Z4-UT-PW-VC-0250: Expenses: (New Expense Item) 1805.93
- CON-Z4-UT-PW-VC-0240: Expenses: (New Expense Item) 6019.78
- CON-Z4-UT-PW-VC-5750: Expenses: (New Expense Item) 3009.89
- CON-Z4-UT-PW-VC-5760: Expenses: (New Expense Item) 9029.67
- CON-Z4-UT-PW-VC-0260: Expenses: (New Expense Item) 1203.96
- CON-Z4-UT-PW-VC-0270: Expenses: (New Expense Item) 3009.89
- CON-Z4-UT-PW-VC-5770: Expenses: (New Expense Item) 6019.78
- CON-Z4-UT-SEA-PL-010: Expenses: (New Expense Item) 4002.89
- CON-Z4-UT-SEA-PL-020: Expenses: (New Expense Item) 2668.59
- CON-Z4-UT-SEA-PL-030: Expenses: (New Expense Item) 8005.78
- CON-Z4-UT-SEA-PL-040: Expenses: (New Expense Item) 2668.59
- CON-Z4-UT-SEA-PL-050: Expenses: (New Expense Item) 4002.89
- CON-Z4-UT-SEA-PL-160: Expenses: (New Expense Item) 5337.19

| ID | WBS | Activity | Duration | Start | Finish | Predecessors | Total float | Free float | Resources | Cost | RPI_P2 - BOQ ITEMS | RPI_P2 - CONSTRUCTION | RPI_P2 - PHASE | RPI_P2 - ZONES | RPI_P2 - AREAS | RPI_P2 - UTILITY NETWORK | Activity Wt% | Weight % | Cost Wt | RPI - PHASE | RPI - CONSTRUCTION | RPI - ZONES | RPI - UTILITY NETWORKS | RPI - TYPE OF WORK |
| --- | --- | --- | --- | --- | --- | --- | --- | --- | --- | --- | --- | --- | --- | --- | --- | --- | --- | --- | --- | --- | --- | --- | --- | --- |
|  | 1 | **Sea Water Line - RTR 300mm dia at Road 3 = 358 Lm (2nd Line)** |  | 2017-04-18 | 2017-06-05 |  |  |  |  |  |  |  |  |  |  |  |  |  |  |  |  |  |  |  |
| CON-Z4-UT-SEA-PL-060 |  | Excavation of Trench (138 Lm) | 1.6d | 2017-04-18 | 2017-04-19 | CON-Z4-UT-SEA-PL-010 SS+5d | 81.2d | 0d | Common Labor / Helper [39 h]; Operator - Excavator [13 h]; Driver - Dump Truck [13 h]; Operator - JCB [13 h]; Excavator [14 h]; Dump Truck [14 h] | 4,002.89 | 1.3.5.30 | CONS | CONS | ZONE-4 | ROAD-3 | SEA-W |  |  |  |  |  |  |  |  |
| CON-Z4-UT-SEA-PL-070 |  | Compaction and Sand bedding (138 Lm) | 2.4d | 2017-04-22 | 2017-04-24 | CON-Z4-UT-SEA-PL-060 SS+3.2d | 81.2d | 0d | Common Labor / Helper [52 h]; Operator - Loader [13 h]; Driver - Dump Truck [13 h]; Operator - Bobcat [13 h]; Operator - JCB [13 h]; Loader [14 h]; Dump Truck [14 h]; Bobcat [14 h]; JCB [14 h] | 2,668.59 | 1.3.5.30 | CONS | CONS | ZONE-4 | ROAD-3 | SEA-W |  |  |  |  |  |  |  |  |
| CON-Z4-UT-SEA-PL-080 |  | Pipe Laying (138 Lm) | 4d | 2017-04-24 | 2017-04-29 | CON-Z4-UT-SEA-PL-070 SS+2.4d | 81.2d | 0d | Plumber [65 h]; Common Labor / Helper [39 h]; RTR Pipe Crew [26 h]; Operator - Mobile Crane [13 h]; Driver - Flat Bed Trailer [13 h]; Mobile Crane ( 25-60 Ton) [14 h]; Flat Bed Trailer [14 h] | 8,005.78 | 1.3.5.30 | CONS | CONS | ZONE-4 | ROAD-3 | SEA-W |  |  |  |  |  |  |  |  |
| CON-Z4-UT-SEA-PL-090 |  | Installation of Thurst Block | 4d | 2017-04-29 | 2017-05-03 | CON-Z4-UT-SEA-PL-080 SS+4d | 81.2d | 0d | Steel Fixer [26 h]; Shuttering Carpenter [52 h]; Concrete Mason [52 h]; Common Labor / Helper [52 h]; Driver - Conc. Transit Mixers [26 h]; Operator - Concrete Pump [26 h]; Concrete Transit Mixers [28 h]; Concrete Pump [28 h] | 2,668.59 | 1.3.5.30 | CONS | CONS | ZONE-4 | ROAD-3 | SEA-W |  |  |  |  |  |  |  |  |
| CON-Z4-UT-SEA-PL-100 |  | Backfilling (358 Lm) | 12d | 2017-05-03 | 2017-05-17 | CON-Z4-UT-SEA-PL-090, CON-Z4-UT-SEA-PL-080 | 81.2d | 7.8d | Common Labor / Helper [52 h]; Operator - Loader [13 h]; Driver - Dump Truck [13 h]; Operator - Bobcat [13 h]; Operator - Asphalt Compactor / Roller [13 h]; Operator - Roller-Compactor (2~10 Ton) [13 h]; Driver - Water Tanker [13 h]; Operator - JCB [13 h]; Loader [14 h]; Dump Truck [14 h]; Bobcat [14 h]; Roller-Compactor (2~10 Ton) [14 h]; Plate Compactor [14 h]; Vibrators [14 h]; Water Tanker [14 h]; JCB [14 h] | 4,002.89 | 1.3.5.30 | CONS | CONS | ZONE-4 | ROAD-3 | SEA-W |  |  |  |  |  |  |  |  |
| CON-Z4-UT-SEA-PL-170 |  | Testing and Precommissioning (358 Lm) | 8d | 2017-05-27 | 2017-06-05 | CON-Z4-UT-SEA-PL-100, CON-Z4-UT-SEA-PL-160 SS+4d | 73.4d | 0d | Plumber [52 h]; Common Labor / Helper [52 h]; RTR Pipe Crew [52 h]; Driver - Water Tanker [26 h]; Water Tanker [28 h] | 5,337.19 | 1.3.5.30 | CONS | CONS | ZONE-4 | ROAD-3 | SEA-W |  |  |  |  |  |  |  |  |
|  | 2 | **Sea Water Line - RTR 150mm dia at Road 3 = 358 Lm** |  | 2017-04-19 | 2017-06-10 |  |  |  |  |  |  |  |  |  |  |  |  |  |  |  |  |  |  |  |
| CON-Z4-UT-SEA-PL-110 |  | Excavation of Trench (138 Lm) | 1.6d | 2017-04-19 | 2017-04-22 | CON-Z4-UT-SEA-PL-060 | 83.6d | 0d | Common Labor / Helper [39 h]; Operator - Excavator [13 h]; Driver - Dump Truck [13 h]; Operator - JCB [13 h]; Excavator [14 h]; Dump Truck [14 h] | 3,767.43 | 1.3.5.30 | CONS | CONS | ZONE-4 | ROAD-3 | SEA-W |  |  |  |  |  |  |  |  |
| CON-Z4-UT-SEA-PL-120 |  | Compaction and Sand bedding (138 Lm) | 2.4d | 2017-04-24 | 2017-04-26 | CON-Z4-UT-SEA-PL-110 SS+3.2d | 83.6d | 0d | Common Labor / Helper [52 h]; Operator - Loader [13 h]; Driver - Dump Truck [13 h]; Operator - Bobcat [13 h]; Operator - JCB [13 h]; Loader [14 h]; Dump Truck [14 h]; Bobcat [14 h]; JCB [14 h] | 2,511.62 | 1.3.5.30 | CONS | CONS | ZONE-4 | ROAD-3 | SEA-W |  |  |  |  |  |  |  |  |
| CON-Z4-UT-SEA-PL-130 |  | Pipe Laying (138 Lm) | 4d | 2017-04-26 | 2017-05-01 | CON-Z4-UT-SEA-PL-120 SS+2.4d | 83.6d | 0d | Plumber [65 h]; Common Labor / Helper [39 h]; RTR Pipe Crew [26 h]; Operator - Mobile Crane [13 h]; Driver - Flat Bed Trailer [13 h]; Mobile Crane ( 25-60 Ton) [14 h]; Flat Bed Trailer [14 h] | 7,534.85 | 1.3.5.30 | CONS | CONS | ZONE-4 | ROAD-3 | SEA-W |  |  |  |  |  |  |  |  |
| CON-Z4-UT-SEA-PL-140 |  | Installation of Thurst Block | 4d | 2017-05-01 | 2017-05-06 | CON-Z4-UT-SEA-PL-130 SS+4d | 83.6d | 0d | Steel Fixer [26 h]; Shuttering Carpenter [52 h]; Concrete Mason [52 h]; Common Labor / Helper [52 h]; Driver - Conc. Transit Mixers [26 h]; Operator - Concrete Pump [26 h]; Concrete Transit Mixers [28 h]; Concrete Pump [28 h] | 2,511.62 | 1.3.5.30 | CONS | CONS | ZONE-4 | ROAD-3 | SEA-W |  |  |  |  |  |  |  |  |
| CON-Z4-UT-SEA-PL-150 |  | Backfilling (358 Lm) | 12d | 2017-05-06 | 2017-05-20 | CON-Z4-UT-SEA-PL-140, CON-Z4-UT-SEA-PL-130 | 83.6d | 10.2d | Common Labor / Helper [52 h]; Operator - Loader [13 h]; Driver - Dump Truck [13 h]; Operator - Bobcat [13 h]; Operator - Asphalt Compactor / Roller [13 h]; Operator - Roller-Compactor (2~10 Ton) [13 h]; Driver - Water Tanker [13 h]; Operator - JCB [13 h]; Loader [14 h]; Dump Truck [14 h]; Bobcat [14 h]; Roller-Compactor (2~10 Ton) [14 h]; Plate Compactor [14 h]; Vibrators [14 h]; Water Tanker [14 h]; JCB [14 h] | 3,767.43 | 1.3.5.30 | CONS | CONS | ZONE-4 | ROAD-3 | SEA-W |  |  |  |  |  |  |  |  |
| CON-Z4-UT-SEA-PL-180 |  | Testing and Precommissioning (358 Lm) | 8d | 2017-05-31 | 2017-06-10 | CON-Z4-UT-SEA-PL-150, CON-Z4-UT-SEA-PL-170 SS+4d | 73.4d | 42.6d | Plumber [52 h]; Common Labor / Helper [52 h]; RTR Pipe Crew [52 h]; Driver - Water Tanker [26 h]; Water Tanker [28 h] | 5,023.23 | 1.3.5.30 | CONS | CONS | ZONE-4 | ROAD-3 | SEA-W |  |  |  |  |  |  |  |  |
|  | 2 | **Sea Water Chambers** |  | 2017-04-13 | 2017-08-02 |  |  |  |  |  |  |  |  |  |  |  |  |  |  |  |  |  |  |  |
|  | 2 | **Chamber - VB-NCL-16 at Road 3** |  | 2017-04-13 | 2017-05-16 |  |  |  |  |  |  |  |  |  |  |  |  |  |  |  |  |  |  |  |
| CON-Z4-UT-SW-NC16-10 |  | Excavation and Compaction | 1.6d | 2017-04-13 | 2017-04-16 | CON-Z4-UT-SEA-PL-010 | 78d | 0d | Operator - Excavator [26 h] | 784.88 | 1.3.5.30 | CONS | CONS | ZONE-4 | ROAD-3 | SEA-W | 0 | 0 | 0.0030836221 | 6 | RPI - CONS | Z2 | PW | MECH |
| CON-Z4-UT-SW-NC16-20 |  | Lean concrete | 0.8d | 2017-04-16 | 2017-04-17 | CON-Z4-UT-SW-NC16-10 | 91.2d | 0d | Concrete Mason [52 h]; Driver - Conc. Transit Mixers [26 h]; Operator - Concrete Pump [26 h] | 470.93 | 1.3.5.30 | CONS | CONS | ZONE-4 | ROAD-3 | SEA-W | 0 | 0 | 0.0003088871 | 6 | RPI - CONS | Z2 | PW | MECH |
| CON-Z4-UT-SW-NC16-50 |  | Formwork for Base Slab | 0.8d | 2017-04-17 | 2017-04-17 | CON-Z4-UT-SW-NC16-20 | 91.2d | 0d | Shuttering Carpenter [78 h]; Common Labor / Helper [52 h] | 784.88 | 1.3.5.30 | CONS | CONS | ZONE-4 | ROAD-3 | SEA-W | 0 | 0 | 0.000308358 | 6 | RPI - CONS | Z2 | PW | MECH |
| CON-Z4-UT-SW-NC16-30 |  | Fabrication & installation of Rebar for Base Slab | 4d | 2017-04-18 | 2017-04-22 | CON-Z4-UT-SW-NC16-50 | 91.2d | 0d | Steel Fixer [78 h] | 784.88 | 1.3.5.30 | CONS | CONS | ZONE-4 | ROAD-3 | SEA-W | 0 | 0 | 0.0015418111 | 6 | RPI - CONS | Z2 | PW | MECH |
| CON-Z4-UT-SW-NC16-40 |  | Fabrication & installation of Rebar for Side walls | 4d | 2017-04-23 | 2017-04-26 | CON-Z4-UT-SW-NC16-30 | 91.2d | 0d | Steel Fixer [78 h] | 784.88 | 1.3.5.30 | CONS | CONS | ZONE-4 | ROAD-3 | SEA-W | 0 | 0 | 0.0030836221 | 6 | RPI - CONS | Z2 | PW | MECH |
| CON-Z4-UT-SW-NC16-70 |  | Formwork for side walls | 4d | 2017-04-23 | 2017-04-27 | CON-Z4-UT-SW-NC16-40 SS+0.8d | 91.2d | 0d | Shuttering Carpenter [78 h]; Common Labor / Helper [26 h]; Scaffolder [52 h] | 1,569.76 | 1.3.5.30 | CONS | CONS | ZONE-4 | ROAD-3 | SEA-W | 0 | 0 | 0.0015418111 | 6 | RPI - CONS | Z2 | PW | MECH |
| CON-Z4-UT-SW-NC16-60 |  | Concrete pouring for base slab | 0.8d | 2017-04-27 | 2017-04-29 | CON-Z4-UT-SW-NC16-70 | 91.2d | 0d | Concrete Mason [78 h]; Common Labor / Helper [26 h]; Finishing Work Crew [52 h]; Driver - Conc. Transit Mixers [26 h]; Operator - Concrete Pump [26 h] | 784.88 | 1.3.5.30 | CONS | CONS | ZONE-4 | ROAD-3 | SEA-W | 0 | 0 | 0.0015418111 | 6 | RPI - CONS | Z2 | PW | MECH |
| CON-Z4-UT-SW-NC16-80 |  | Concrete pouring for Side Wall | 0.8d | 2017-04-29 | 2017-04-30 | CON-Z4-UT-SW-NC16-60 | 91.2d | 0d | Concrete Mason [78 h]; Common Labor / Helper [26 h]; Finishing Work Crew [52 h]; Driver - Conc. Transit Mixers [26 h]; Operator - Concrete Pump [26 h] | 1,569.76 | 1.3.5.30 | CONS | CONS | ZONE-4 | ROAD-3 | SEA-W | 0 | 0 | 0.0040086961 | 6 | RPI - CONS | Z2 | PW | MECH |
| CON-Z4-UT-SW-NC16-90 |  | Formwork removal and concrete patching | 1.6d | 2017-04-30 | 2017-05-01 | CON-Z4-UT-SW-NC16-80 | 91.2d | 0d | Shuttering Carpenter [78 h]; Scaffolder [26 h]; Finishing Work Crew [52 h] | 313.95 | 1.3.5.30 | CONS | CONS | ZONE-4 | ROAD-3 | SEA-W | 0 | 0 | 0.0015418111 | 6 | RPI - CONS | Z2 | PW | MECH |
| CON-Z4-UT-SW-NC16-92 |  | Concrete Supports | 0.8d | 2017-05-02 | 2017-05-02 | CON-Z4-UT-SW-NC16-90 | 91.2d | 0d | Shuttering Carpenter [26 h]; Concrete Mason [26 h]; Common Labor / Helper [26 h] | 470.93 | 1.3.5.30 | CONS | CONS | ZONE-4 | ROAD-3 | SEA-W | 0 | 0 | 0.000616716 | 6 | RPI - CONS | Z2 | PW | MECH |
| CON-Z4-UT-SW-NC16-91 |  | Installation of Pipe Connections / Closing of Openings | 3.2d | 2017-05-02 | 2017-05-06 | CON-Z4-UT-SW-NC16-92 | 91.2d | 0d | Shuttering Carpenter [26 h]; Concrete Mason [26 h]; Plumber [26 h]; Common Labor / Helper [26 h] | 1,569.76 | 1.3.5.30 | CONS | CONS | ZONE-4 | ROAD-3 | SEA-W | 0 | 0 | 0.0055505071 | 6 | RPI - CONS | Z2 | PW | MECH |
| CON-Z4-UT-SW-NC16-95 |  | Installation of Dismantling joints | 2.4d | 2017-05-02 | 2017-05-06 | CON-Z4-UT-SW-NC16-91 SS, PR-Z4-UT-SE-203-0080 | 92.8d | 0d | Common Labor / Helper [26 h]; RTR Pipe Crew [26 h] | 784.88 | 1.3.5.30 | CONS | CONS | ZONE-4 | ROAD-3 | SEA-W |  |  |  |  |  |  |  |  |
| CON-Z4-UT-SW-NC16-96 |  | Installation of Valves | 4d | 2017-05-06 | 2017-05-10 | CON-Z4-UT-SW-NC16-95, PR-Z4-UT-SE-202-0080 | 92.8d | 1.6d | Common Labor / Helper [26 h]; RTR Pipe Crew [26 h] | 2,354.64 | 1.3.5.30 | CONS | CONS | ZONE-4 | ROAD-3 | SEA-W |  |  |  |  |  |  |  |  |
| CON-Z4-UT-SW-NC16-93 |  | Damp Proof Coating | 0.8d | 2017-05-07 | 2017-05-07 | CON-Z4-UT-SW-NC16-90, CON-Z4-UT-SW-NC16-91 | 91.2d | 0d | Painter [52 h]; Water Proofing Crew [52 h] | 313.95 | 1.3.5.30 | CONS | CONS | ZONE-4 | ROAD-3 | SEA-W | 0 | 0 | 0.0015418111 | 6 | RPI - CONS | Z2 | PW | MECH |
| CON-Z4-UT-SW-NC16-94 |  | Backfilling & Compaction | 4d | 2017-05-07 | 2017-05-11 | CON-Z4-UT-SW-NC16-93 | 91.2d | 0d | Common Labor / Helper [52 h]; Driver - Dump Truck [26 h]; Operator - Bobcat [26 h]; Operator - Roller-Compactor (2~10 Ton) [26 h]; Driver - Water Tanker [26 h]; Operator - JCB [26 h]; Bobcat [28 h]; Roller-Compactor (2~10 Ton) [28 h]; Roller-Compactor (25 Ton) [28 h]; Water Tanker [28 h] | 784.88 | 1.3.5.30 | CONS | CONS | ZONE-4 | ROAD-3 | SEA-W | 0 | 0 | 0.0037003381 | 6 | RPI - CONS | Z2 | PW | MECH |
| CON-Z4-UT-SW-NC16-97 |  | Installation of Roof Slab, Manhole Cover, Accessories & Finishes | 4d | 2017-05-11 | 2017-05-16 | CON-Z4-UT-SW-NC16-96, CON-Z4-UT-SW-NC16-94 | 91.2d | 11.4d | Common Labor / Helper [52 h]; Finishing Work Crew [52 h] | 1,569.76 | 1.3.5.30 | CONS | CONS | ZONE-4 | ROAD-3 | SEA-W |  |  |  |  |  |  |  |  |

Notes:
- CON-Z4-UT-SEA-PL-060: Expenses: (New Expense Item) 4002.89
- CON-Z4-UT-SEA-PL-070: Expenses: (New Expense Item) 2668.59
- CON-Z4-UT-SEA-PL-080: Expenses: (New Expense Item) 8005.78
- CON-Z4-UT-SEA-PL-090: Expenses: (New Expense Item) 2668.59
- CON-Z4-UT-SEA-PL-100: Expenses: (New Expense Item) 4002.89
- CON-Z4-UT-SEA-PL-170: Expenses: (New Expense Item) 5337.19
- CON-Z4-UT-SEA-PL-110: Expenses: (New Expense Item) 3767.43
- CON-Z4-UT-SEA-PL-120: Expenses: (New Expense Item) 2511.62
- CON-Z4-UT-SEA-PL-130: Expenses: (New Expense Item) 7534.85
- CON-Z4-UT-SEA-PL-140: Expenses: (New Expense Item) 2511.62
- CON-Z4-UT-SEA-PL-150: Expenses: (New Expense Item) 3767.43
- CON-Z4-UT-SEA-PL-180: Expenses: (New Expense Item) 5023.23
- CON-Z4-UT-SW-NC16-10: Expenses: (New Expense Item) 784.88
- CON-Z4-UT-SW-NC16-20: Expenses: (New Expense Item) 470.93
- CON-Z4-UT-SW-NC16-50: Expenses: (New Expense Item) 784.88
- CON-Z4-UT-SW-NC16-30: Expenses: (New Expense Item) 784.88
- CON-Z4-UT-SW-NC16-40: Expenses: (New Expense Item) 784.88
- CON-Z4-UT-SW-NC16-70: Expenses: (New Expense Item) 1569.76
- CON-Z4-UT-SW-NC16-60: Expenses: (New Expense Item) 784.88
- CON-Z4-UT-SW-NC16-80: Expenses: (New Expense Item) 1569.76
- CON-Z4-UT-SW-NC16-90: Expenses: (New Expense Item) 313.95
- CON-Z4-UT-SW-NC16-92: Expenses: (New Expense Item) 470.93
- CON-Z4-UT-SW-NC16-91: Expenses: (New Expense Item) 1569.76
- CON-Z4-UT-SW-NC16-95: Expenses: (New Expense Item) 784.88
- CON-Z4-UT-SW-NC16-96: Expenses: (New Expense Item) 2354.64
- CON-Z4-UT-SW-NC16-93: Expenses: (New Expense Item) 313.95
- CON-Z4-UT-SW-NC16-94: Expenses: (New Expense Item) 784.88
- CON-Z4-UT-SW-NC16-97: Expenses: (New Expense Item) 1569.76

| ID | WBS | Activity | Duration | Start | Finish | Predecessors | Total float | Free float | Resources | Cost | Activity Wt% | Weight % | Cost Wt | RPI - PHASE | RPI - CONSTRUCTION | RPI - ZONES | RPI - UTILITY NETWORKS | RPI - TYPE OF WORK | RPI_P2 - BOQ ITEMS | RPI_P2 - CONSTRUCTION | RPI_P2 - PHASE | RPI_P2 - ZONES | RPI_P2 - AREAS | RPI_P2 - UTILITY NETWORK |
| --- | --- | --- | --- | --- | --- | --- | --- | --- | --- | --- | --- | --- | --- | --- | --- | --- | --- | --- | --- | --- | --- | --- | --- | --- |
|  | 1 | **Wash Down Valve Chamber (WDV-4) at Road 3** |  | 2017-04-22 | 2017-05-31 |  |  |  |  |  |  |  |  |  |  |  |  |  |  |  |  |  |  |  |
| CON-Z4-UT-SW-WD4-010 |  | Excavation and Compaction | 1.6d | 2017-04-22 | 2017-04-23 | CON-Z4-UT-SW-NC16-10 FS+5d | 78d | 0d | Operator - Excavator [26 h] | 784.88 | 0 | 0 | 0.0030836221 | 6 | RPI - CONS | Z2 | PW | MECH | 1.3.5.30 | CONS | CONS | ZONE-4 | ROAD-3 | SEA-W |
| CON-Z4-UT-SW-WD4-020 |  | Lean concrete | 0.8d | 2017-04-24 | 2017-04-24 | CON-Z4-UT-SW-WD4-010 | 79.8d | 0d | Concrete Mason [52 h]; Driver - Conc. Transit Mixers [26 h]; Operator - Concrete Pump [26 h] | 470.93 | 0 | 0 | 0.0003088871 | 6 | RPI - CONS | Z2 | PW | MECH | 1.3.5.30 | CONS | CONS | ZONE-4 | ROAD-3 | SEA-W |
| CON-Z4-UT-SW-WD4-050 |  | Formwork for Base Slab | 0.8d | 2017-04-24 | 2017-04-25 | CON-Z4-UT-SW-WD4-020 | 79.8d | 0d | Shuttering Carpenter [78 h]; Common Labor / Helper [52 h] | 784.88 | 0 | 0 | 0.000308358 | 6 | RPI - CONS | Z2 | PW | MECH | 1.3.5.30 | CONS | CONS | ZONE-4 | ROAD-3 | SEA-W |
| CON-Z4-UT-SW-WD4-030 |  | Fabrication & installation of Rebar for Base Slab | 4d | 2017-04-25 | 2017-04-30 | CON-Z4-UT-SW-WD4-050 | 79.8d | 0d | Steel Fixer [78 h] | 784.88 | 0 | 0 | 0.0015418111 | 6 | RPI - CONS | Z2 | PW | MECH | 1.3.5.30 | CONS | CONS | ZONE-4 | ROAD-3 | SEA-W |
| CON-Z4-UT-SW-WD4-040 |  | Fabrication & installation of Rebar for Side walls | 4d | 2017-04-30 | 2017-05-04 | CON-Z4-UT-SW-WD4-030 | 79.8d | 0d | Steel Fixer [78 h] | 784.88 | 0 | 0 | 0.0030836221 | 6 | RPI - CONS | Z2 | PW | MECH | 1.3.5.30 | CONS | CONS | ZONE-4 | ROAD-3 | SEA-W |
| CON-Z4-UT-SW-WD4-070 |  | Formwork for side walls | 4d | 2017-05-01 | 2017-05-06 | CON-Z4-UT-SW-WD4-040 SS+0.8d | 79.8d | 0d | Shuttering Carpenter [78 h]; Common Labor / Helper [26 h]; Scaffolder [52 h] | 1,569.76 | 0 | 0 | 0.0015418111 | 6 | RPI - CONS | Z2 | PW | MECH | 1.3.5.30 | CONS | CONS | ZONE-4 | ROAD-3 | SEA-W |
| CON-Z4-UT-SW-WD4-060 |  | Concrete pouring for base slab | 0.8d | 2017-05-06 | 2017-05-07 | CON-Z4-UT-SW-WD4-070 | 79.8d | 0d | Concrete Mason [78 h]; Common Labor / Helper [26 h]; Finishing Work Crew [52 h]; Driver - Conc. Transit Mixers [26 h]; Operator - Concrete Pump [26 h] | 784.88 | 0 | 0 | 0.0015418111 | 6 | RPI - CONS | Z2 | PW | MECH | 1.3.5.30 | CONS | CONS | ZONE-4 | ROAD-3 | SEA-W |
| CON-Z4-UT-SW-WD4-080 |  | Concrete pouring for Side Wall | 0.8d | 2017-05-07 | 2017-05-07 | CON-Z4-UT-SW-WD4-060 | 79.8d | 0d | Concrete Mason [78 h]; Common Labor / Helper [26 h]; Finishing Work Crew [52 h]; Driver - Conc. Transit Mixers [26 h]; Operator - Concrete Pump [26 h] | 1,569.76 | 0 | 0 | 0.0040086961 | 6 | RPI - CONS | Z2 | PW | MECH | 1.3.5.30 | CONS | CONS | ZONE-4 | ROAD-3 | SEA-W |
| CON-Z4-UT-SW-WD4-090 |  | Formwork removal and concrete patching | 1.6d | 2017-05-08 | 2017-05-09 | CON-Z4-UT-SW-WD4-080 | 79.8d | 0d | Shuttering Carpenter [78 h]; Scaffolder [26 h]; Finishing Work Crew [52 h] | 313.95 | 0 | 0 | 0.0015418111 | 6 | RPI - CONS | Z2 | PW | MECH | 1.3.5.30 | CONS | CONS | ZONE-4 | ROAD-3 | SEA-W |
| CON-Z4-UT-SW-WD4-110 |  | Concrete Supports | 0.8d | 2017-05-09 | 2017-05-10 | CON-Z4-UT-SW-WD4-090 | 79.8d | 0d | Shuttering Carpenter [26 h]; Concrete Mason [26 h]; Common Labor / Helper [26 h] | 470.93 | 0 | 0 | 0.000616716 | 6 | RPI - CONS | Z2 | PW | MECH | 1.3.5.30 | CONS | CONS | ZONE-4 | ROAD-3 | SEA-W |
| CON-Z4-UT-SW-WD4-100 |  | Installation of Valves / Pipe Connections / Closing of Openings | 3.2d | 2017-05-10 | 2017-05-14 | CON-Z4-UT-SW-WD4-110, PR-Z4-UT-SE-202-0080 | 79.8d | 0d | Shuttering Carpenter [26 h]; Concrete Mason [26 h]; Common Labor / Helper [26 h]; RTR Pipe Crew [26 h] | 3,139.52 | 0 | 0 | 0.0055505071 | 6 | RPI - CONS | Z2 | PW | MECH | 1.3.5.30 | CONS | CONS | ZONE-4 | ROAD-3 | SEA-W |
| CON-Z4-UT-SW-WD4-120 |  | Damp Proof Coating | 0.8d | 2017-05-14 | 2017-05-15 | CON-Z4-UT-SW-WD4-090, CON-Z4-UT-SW-WD4-100 | 79.8d | 0d | Painter [52 h]; Water Proofing Crew [52 h] | 313.95 | 0 | 0 | 0.0015418111 | 6 | RPI - CONS | Z2 | PW | MECH | 1.3.5.30 | CONS | CONS | ZONE-4 | ROAD-3 | SEA-W |
| CON-Z4-UT-SW-WD4-130 |  | Backfilling & Compaction | 4d | 2017-05-15 | 2017-05-20 | CON-Z4-UT-SW-WD4-120 | 79.8d | 0d | Common Labor / Helper [52 h]; Driver - Dump Truck [26 h]; Operator - Bobcat [26 h]; Operator - Roller-Compactor (2~10 Ton) [26 h]; Driver - Water Tanker [26 h]; Operator - JCB [26 h]; Bobcat [28 h]; Roller-Compactor (2~10 Ton) [28 h]; Roller-Compactor (25 Ton) [28 h]; Water Tanker [28 h] | 1,569.76 | 0 | 0 | 0.0037003381 | 6 | RPI - CONS | Z2 | PW | MECH | 1.3.5.30 | CONS | CONS | ZONE-4 | ROAD-3 | SEA-W |
| CON-Z4-UT-SW-WD4-140 |  | Installation of Roof Slab, Manhole Cover, Accessories & Finishes | 5.6d | 2017-05-25 | 2017-05-31 | CON-Z4-UT-SW-WD4-130 FS+4.8d, CON-Z4-UT-SW-NC16-97 SS | 79.8d | 1.8d | Common Labor / Helper [52 h]; Finishing Work Crew [52 h] | 2,354.64 | 0 | 0 | 0.002466885 | 6 | RPI - CONS | Z2 | PW | MECH | 1.3.5.30 | CONS | CONS | ZONE-4 | ROAD-3 | SEA-W |
|  | 3 | **Air Release Valve Chamber (AV-10) at Road 3** |  | 2017-04-30 | 2017-05-31 |  |  |  |  |  |  |  |  |  |  |  |  |  |  |  |  |  |  |  |
| CON-Z4-UT-SW-AV10-10 |  | Excavation and Compaction | 1.6d | 2017-04-30 | 2017-05-01 | CON-Z4-UT-SW-WD4-010 FS+5d | 78d | 0d | Operator - Excavator [26 h] | 784.88 | 0 | 0 | 0.0030836221 | 6 | RPI - CONS | Z2 | PW | MECH | 1.3.5.30 | CONS | CONS | ZONE-4 | ROAD-3 | SEA-W |
| CON-Z4-UT-SW-AV10-20 |  | Lean concrete | 0.8d | 2017-05-01 | 2017-05-02 | CON-Z4-UT-SW-AV10-10 | 78d | 0d | Concrete Mason [52 h]; Driver - Conc. Transit Mixers [26 h]; Operator - Concrete Pump [26 h] | 470.93 | 0 | 0 | 0.0003088871 | 6 | RPI - CONS | Z2 | PW | MECH | 1.3.5.30 | CONS | CONS | ZONE-4 | ROAD-3 | SEA-W |
| CON-Z4-UT-SW-AV10-50 |  | Formwork for Base Slab | 0.8d | 2017-05-02 | 2017-05-03 | CON-Z4-UT-SW-AV10-20 | 78d | 0d | Shuttering Carpenter [78 h]; Common Labor / Helper [52 h] | 784.88 | 0 | 0 | 0.000308358 | 6 | RPI - CONS | Z2 | PW | MECH | 1.3.5.30 | CONS | CONS | ZONE-4 | ROAD-3 | SEA-W |
| CON-Z4-UT-SW-AV10-30 |  | Fabrication & installation of Rebar for Base Slab | 4d | 2017-05-03 | 2017-05-08 | CON-Z4-UT-SW-AV10-50 | 78d | 0d | Steel Fixer [78 h] | 784.88 | 0 | 0 | 0.0015418111 | 6 | RPI - CONS | Z2 | PW | MECH | 1.3.5.30 | CONS | CONS | ZONE-4 | ROAD-3 | SEA-W |
| CON-Z4-UT-SW-AV10-40 |  | Fabrication & installation of Rebar for Side walls | 4d | 2017-05-08 | 2017-05-13 | CON-Z4-UT-SW-AV10-30 | 78d | 0d | Steel Fixer [78 h] | 784.88 | 0 | 0 | 0.0030836221 | 6 | RPI - CONS | Z2 | PW | MECH | 1.3.5.30 | CONS | CONS | ZONE-4 | ROAD-3 | SEA-W |
| CON-Z4-UT-SW-AV10-70 |  | Formwork for side walls | 4d | 2017-05-09 | 2017-05-13 | CON-Z4-UT-SW-AV10-40 SS+0.8d | 78d | 0d | Shuttering Carpenter [78 h]; Common Labor / Helper [26 h]; Scaffolder [52 h] | 1,569.76 | 0 | 0 | 0.0015418111 | 6 | RPI - CONS | Z2 | PW | MECH | 1.3.5.30 | CONS | CONS | ZONE-4 | ROAD-3 | SEA-W |
| CON-Z4-UT-SW-AV10-60 |  | Concrete pouring for base slab | 0.8d | 2017-05-14 | 2017-05-14 | CON-Z4-UT-SW-AV10-70 | 78d | 0d | Concrete Mason [78 h]; Common Labor / Helper [26 h]; Finishing Work Crew [52 h]; Driver - Conc. Transit Mixers [26 h]; Operator - Concrete Pump [26 h] | 784.88 | 0 | 0 | 0.0015418111 | 6 | RPI - CONS | Z2 | PW | MECH | 1.3.5.30 | CONS | CONS | ZONE-4 | ROAD-3 | SEA-W |
| CON-Z4-UT-SW-AV10-80 |  | Concrete pouring for Side Wall | 0.8d | 2017-05-14 | 2017-05-15 | CON-Z4-UT-SW-AV10-60 | 78d | 0d | Concrete Mason [78 h]; Common Labor / Helper [26 h]; Finishing Work Crew [52 h]; Driver - Conc. Transit Mixers [26 h]; Operator - Concrete Pump [26 h] | 1,569.76 | 0 | 0 | 0.0040086961 | 6 | RPI - CONS | Z2 | PW | MECH | 1.3.5.30 | CONS | CONS | ZONE-4 | ROAD-3 | SEA-W |
| CON-Z4-UT-SW-AV10-90 |  | Formwork removal and concrete patching | 1.6d | 2017-05-15 | 2017-05-17 | CON-Z4-UT-SW-AV10-80 | 78d | 0d | Shuttering Carpenter [78 h]; Scaffolder [26 h]; Finishing Work Crew [52 h] | 313.95 | 0 | 0 | 0.0015418111 | 6 | RPI - CONS | Z2 | PW | MECH | 1.3.5.30 | CONS | CONS | ZONE-4 | ROAD-3 | SEA-W |
| CON-Z4-UT-SW-AV10-92 |  | Concrete Supports | 0.8d | 2017-05-17 | 2017-05-17 | CON-Z4-UT-SW-AV10-90 | 78d | 0d | Shuttering Carpenter [26 h]; Concrete Mason [26 h]; Common Labor / Helper [26 h] | 470.93 | 0 | 0 | 0.000616716 | 6 | RPI - CONS | Z2 | PW | MECH | 1.3.5.30 | CONS | CONS | ZONE-4 | ROAD-3 | SEA-W |
| CON-Z4-UT-SW-AV10-91 |  | Installation of Pipe Connections / Closing of Openings | 3.2d | 2017-05-18 | 2017-05-22 | CON-Z4-UT-SW-AV10-92 | 78d | 0d | Shuttering Carpenter [26 h]; Concrete Mason [26 h]; Plumber [26 h]; Common Labor / Helper [26 h] | 1,569.76 | 0 | 0 | 0.0055505071 | 6 | RPI - CONS | Z2 | PW | MECH | 1.3.5.30 | CONS | CONS | ZONE-4 | ROAD-3 | SEA-W |
| CON-Z4-UT-SW-AV10-95 |  | Installation of Dismantling joints | 2.4d | 2017-05-18 | 2017-05-21 | CON-Z4-UT-SW-AV10-91 SS, PR-Z4-UT-SE-203-0080 | 79.6d | 0d | Common Labor / Helper [26 h]; RTR Pipe Crew [26 h] | 784.88 |  |  |  |  |  |  |  |  | 1.3.5.30 | CONS | CONS | ZONE-4 | ROAD-3 | SEA-W |
| CON-Z4-UT-SW-AV10-96 |  | Installation of Valves | 4d | 2017-05-21 | 2017-05-25 | CON-Z4-UT-SW-AV10-95 | 79.6d | 1.6d | Common Labor / Helper [26 h]; RTR Pipe Crew [26 h] | 2,354.64 |  |  |  |  |  |  |  |  | 1.3.5.30 | CONS | CONS | ZONE-4 | ROAD-3 | SEA-W |
| CON-Z4-UT-SW-AV10-93 |  | Damp Proof Coating | 0.8d | 2017-05-22 | 2017-05-22 | CON-Z4-UT-SW-AV10-90, CON-Z4-UT-SW-AV10-91 | 78d | 0d | Painter [52 h]; Water Proofing Crew [52 h] | 313.95 | 0 | 0 | 0.0015418111 | 6 | RPI - CONS | Z2 | PW | MECH | 1.3.5.30 | CONS | CONS | ZONE-4 | ROAD-3 | SEA-W |
| CON-Z4-UT-SW-AV10-94 |  | Backfilling & Compaction | 4d | 2017-05-23 | 2017-05-27 | CON-Z4-UT-SW-AV10-93 | 78d | 0d | Common Labor / Helper [52 h]; Driver - Dump Truck [26 h]; Operator - Bobcat [26 h]; Operator - Roller-Compactor (2~10 Ton) [26 h]; Driver - Water Tanker [26 h]; Operator - JCB [26 h]; Bobcat [28 h]; Roller-Compactor (2~10 Ton) [28 h]; Water Tanker [28 h]; Roller-Compactor (25 Ton) [28 h] | 784.88 | 0 | 0 | 0.0037003381 | 6 | RPI - CONS | Z2 | PW | MECH | 1.3.5.30 | CONS | CONS | ZONE-4 | ROAD-3 | SEA-W |
| CON-Z4-UT-SW-AV10-97 |  | Installation of Roof Slab, Manhole Cover, Accessories & Finishes | 4d | 2017-05-28 | 2017-05-31 | CON-Z4-UT-SW-AV10-94, CON-Z4-UT-SW-WD4-140 SS, CON-Z4-UT-SW-AV10-96 | 78d | 0d | Common Labor / Helper [52 h]; Finishing Work Crew [52 h] | 1,569.76 |  |  |  |  |  |  |  |  | 1.3.5.30 | CONS | CONS | ZONE-4 | ROAD-3 | SEA-W |

Notes:
- CON-Z4-UT-SW-WD4-010: Expenses: (New Expense Item) 784.88
- CON-Z4-UT-SW-WD4-020: Expenses: (New Expense Item) 470.93
- CON-Z4-UT-SW-WD4-050: Expenses: (New Expense Item) 784.88
- CON-Z4-UT-SW-WD4-030: Expenses: (New Expense Item) 784.88
- CON-Z4-UT-SW-WD4-040: Expenses: (New Expense Item) 784.88
- CON-Z4-UT-SW-WD4-070: Expenses: (New Expense Item) 1569.76
- CON-Z4-UT-SW-WD4-060: Expenses: (New Expense Item) 784.88
- CON-Z4-UT-SW-WD4-080: Expenses: (New Expense Item) 1569.76
- CON-Z4-UT-SW-WD4-090: Expenses: (New Expense Item) 313.95
- CON-Z4-UT-SW-WD4-110: Expenses: (New Expense Item) 470.93
- CON-Z4-UT-SW-WD4-100: Expenses: (New Expense Item) 3139.52
- CON-Z4-UT-SW-WD4-120: Expenses: (New Expense Item) 313.95
- CON-Z4-UT-SW-WD4-130: Expenses: (New Expense Item) 1569.76
- CON-Z4-UT-SW-WD4-140: Expenses: (New Expense Item) 2354.64
- CON-Z4-UT-SW-AV10-10: Expenses: (New Expense Item) 784.88
- CON-Z4-UT-SW-AV10-20: Expenses: (New Expense Item) 470.93
- CON-Z4-UT-SW-AV10-50: Expenses: (New Expense Item) 784.88
- CON-Z4-UT-SW-AV10-30: Expenses: (New Expense Item) 784.88
- CON-Z4-UT-SW-AV10-40: Expenses: (New Expense Item) 784.88
- CON-Z4-UT-SW-AV10-70: Expenses: (New Expense Item) 1569.76
- CON-Z4-UT-SW-AV10-60: Expenses: (New Expense Item) 784.88
- CON-Z4-UT-SW-AV10-80: Expenses: (New Expense Item) 1569.76
- CON-Z4-UT-SW-AV10-90: Expenses: (New Expense Item) 313.95
- CON-Z4-UT-SW-AV10-92: Expenses: (New Expense Item) 470.93
- CON-Z4-UT-SW-AV10-91: Expenses: (New Expense Item) 1569.76
- CON-Z4-UT-SW-AV10-95: Expenses: (New Expense Item) 784.88
- CON-Z4-UT-SW-AV10-96: Expenses: (New Expense Item) 2354.64
- CON-Z4-UT-SW-AV10-93: Expenses: (New Expense Item) 313.95
- CON-Z4-UT-SW-AV10-94: Expenses: (New Expense Item) 784.88
- CON-Z4-UT-SW-AV10-97: Expenses: (New Expense Item) 1569.76

| ID | WBS | Activity | Duration | Start | Finish | Predecessors | Total float | Free float | Resources | Cost | Activity Wt% | Weight % | Cost Wt | RPI - PHASE | RPI - CONSTRUCTION | RPI - ZONES | RPI - UTILITY NETWORKS | RPI - TYPE OF WORK | RPI_P2 - BOQ ITEMS | RPI_P2 - CONSTRUCTION | RPI_P2 - PHASE | RPI_P2 - ZONES | RPI_P2 - AREAS | RPI_P2 - UTILITY NETWORK |
| --- | --- | --- | --- | --- | --- | --- | --- | --- | --- | --- | --- | --- | --- | --- | --- | --- | --- | --- | --- | --- | --- | --- | --- | --- |
|  | 16 | **Chamber - VB-NCL-15 at Road 3** |  | 2017-05-01 | 2017-06-05 |  |  |  |  |  |  |  |  |  |  |  |  |  |  |  |  |  |  |  |
| CON-Z4-UT-SW-NC15-10 |  | Excavation and Compaction | 1.6d | 2017-05-01 | 2017-05-03 | CON-Z4-UT-SW-AV10-10 | 80.4d | 0d | Operator - Excavator [26 h] | 784.88 | 0 | 0 | 0.0030836221 | 6 | RPI - CONS | Z2 | PW | MECH | 1.3.5.30 | CONS | CONS | ZONE-4 | ROAD-3 | SEA-W |
| CON-Z4-UT-SW-NC15-20 |  | Lean concrete | 0.8d | 2017-05-03 | 2017-05-03 | CON-Z4-UT-SW-NC15-10 | 80.4d | 0d | Concrete Mason [52 h]; Driver - Conc. Transit Mixers [26 h]; Operator - Concrete Pump [26 h] | 470.93 | 0 | 0 | 0.0003088871 | 6 | RPI - CONS | Z2 | PW | MECH | 1.3.5.30 | CONS | CONS | ZONE-4 | ROAD-3 | SEA-W |
| CON-Z4-UT-SW-NC15-50 |  | Formwork for Base Slab | 0.8d | 2017-05-04 | 2017-05-04 | CON-Z4-UT-SW-NC15-20 | 80.4d | 0d | Shuttering Carpenter [78 h]; Common Labor / Helper [52 h] | 784.88 | 0 | 0 | 0.000308358 | 6 | RPI - CONS | Z2 | PW | MECH | 1.3.5.30 | CONS | CONS | ZONE-4 | ROAD-3 | SEA-W |
| CON-Z4-UT-SW-NC15-30 |  | Fabrication & installation of Rebar for Base Slab | 4d | 2017-05-04 | 2017-05-09 | CON-Z4-UT-SW-NC15-50 | 80.4d | 0d | Steel Fixer [78 h] | 784.88 | 0 | 0 | 0.0015418111 | 6 | RPI - CONS | Z2 | PW | MECH | 1.3.5.30 | CONS | CONS | ZONE-4 | ROAD-3 | SEA-W |
| CON-Z4-UT-SW-NC15-40 |  | Fabrication & installation of Rebar for Side walls | 4d | 2017-05-09 | 2017-05-14 | CON-Z4-UT-SW-NC15-30 | 80.4d | 0d | Steel Fixer [78 h] | 784.88 | 0 | 0 | 0.0030836221 | 6 | RPI - CONS | Z2 | PW | MECH | 1.3.5.30 | CONS | CONS | ZONE-4 | ROAD-3 | SEA-W |
| CON-Z4-UT-SW-NC15-70 |  | Formwork for side walls | 4d | 2017-05-10 | 2017-05-15 | CON-Z4-UT-SW-NC15-40 SS+0.8d | 80.4d | 0d | Shuttering Carpenter [78 h]; Common Labor / Helper [26 h]; Scaffolder [52 h] | 1,569.76 | 0 | 0 | 0.0015418111 | 6 | RPI - CONS | Z2 | PW | MECH | 1.3.5.30 | CONS | CONS | ZONE-4 | ROAD-3 | SEA-W |
| CON-Z4-UT-SW-NC15-60 |  | Concrete pouring for base slab | 0.8d | 2017-05-15 | 2017-05-16 | CON-Z4-UT-SW-NC15-70 | 80.4d | 0d | Concrete Mason [78 h]; Common Labor / Helper [26 h]; Finishing Work Crew [52 h]; Driver - Conc. Transit Mixers [26 h]; Operator - Concrete Pump [26 h] | 784.88 | 0 | 0 | 0.0015418111 | 6 | RPI - CONS | Z2 | PW | MECH | 1.3.5.30 | CONS | CONS | ZONE-4 | ROAD-3 | SEA-W |
| CON-Z4-UT-SW-NC15-80 |  | Concrete pouring for Side Wall | 0.8d | 2017-05-16 | 2017-05-17 | CON-Z4-UT-SW-NC15-60 | 80.4d | 0d | Concrete Mason [78 h]; Common Labor / Helper [26 h]; Finishing Work Crew [52 h]; Driver - Conc. Transit Mixers [26 h]; Operator - Concrete Pump [26 h] | 1,569.76 | 0 | 0 | 0.0040086961 | 6 | RPI - CONS | Z2 | PW | MECH | 1.3.5.30 | CONS | CONS | ZONE-4 | ROAD-3 | SEA-W |
| CON-Z4-UT-SW-NC15-90 |  | Formwork removal and concrete patching | 1.6d | 2017-05-17 | 2017-05-18 | CON-Z4-UT-SW-NC15-80 | 80.4d | 0d | Shuttering Carpenter [78 h]; Scaffolder [26 h]; Finishing Work Crew [52 h] | 313.95 | 0 | 0 | 0.0015418111 | 6 | RPI - CONS | Z2 | PW | MECH | 1.3.5.30 | CONS | CONS | ZONE-4 | ROAD-3 | SEA-W |
| CON-Z4-UT-SW-NC15-92 |  | Concrete Supports | 0.8d | 2017-05-18 | 2017-05-20 | CON-Z4-UT-SW-NC15-90 | 80.4d | 0d | Shuttering Carpenter [26 h]; Concrete Mason [26 h]; Common Labor / Helper [26 h] | 470.93 | 0 | 0 | 0.000616716 | 6 | RPI - CONS | Z2 | PW | MECH | 1.3.5.30 | CONS | CONS | ZONE-4 | ROAD-3 | SEA-W |
| CON-Z4-UT-SW-NC15-91 |  | Installation of Pipe Connections / Closing of Openings | 3.2d | 2017-05-20 | 2017-05-23 | CON-Z4-UT-SW-NC15-92 | 80.4d | 0d | Common Labor / Helper [26 h]; Shuttering Carpenter [26 h]; Concrete Mason [26 h]; Plumber [26 h] | 1,569.76 | 0 | 0 | 0.0055505071 | 6 | RPI - CONS | Z2 | PW | MECH | 1.3.5.30 | CONS | CONS | ZONE-4 | ROAD-3 | SEA-W |
| CON-Z4-UT-SW-NC15-95 |  | Installation of Dismantling joints | 2.4d | 2017-05-20 | 2017-05-22 | CON-Z4-UT-SW-NC15-91 SS | 82d | 0d | Common Labor / Helper [26 h]; RTR Pipe Crew [26 h] | 784.88 |  |  |  |  |  |  |  |  | 1.3.5.30 | CONS | CONS | ZONE-4 | ROAD-3 | SEA-W |
| CON-Z4-UT-SW-NC15-96 |  | Installation of Valves | 4d | 2017-05-23 | 2017-05-27 | CON-Z4-UT-SW-NC15-95 | 82d | 4d | Common Labor / Helper [26 h]; RTR Pipe Crew [26 h] | 2,354.64 |  |  |  |  |  |  |  |  | 1.3.5.30 | CONS | CONS | ZONE-4 | ROAD-3 | SEA-W |
| CON-Z4-UT-SW-NC15-93 |  | Damp Proof Coating | 0.8d | 2017-05-23 | 2017-05-24 | CON-Z4-UT-SW-NC15-91, CON-Z4-UT-SW-NC15-90 | 80.4d | 0d | Painter [52 h]; Water Proofing Crew [52 h] | 313.95 | 0 | 0 | 0.0015418111 | 6 | RPI - CONS | Z2 | PW | MECH | 1.3.5.30 | CONS | CONS | ZONE-4 | ROAD-3 | SEA-W |
| CON-Z4-UT-SW-NC15-94 |  | Backfilling & Compaction | 4d | 2017-05-24 | 2017-05-29 | CON-Z4-UT-SW-NC15-93 | 80.4d | 2.4d | Common Labor / Helper [52 h]; Driver - Dump Truck [26 h]; Operator - Bobcat [26 h]; Operator - Roller-Compactor (2~10 Ton) [26 h]; Driver - Water Tanker [26 h]; Operator - JCB [26 h]; Bobcat [28 h]; Roller-Compactor (2~10 Ton) [28 h]; Roller-Compactor (25 Ton) [28 h]; Water Tanker [28 h] | 784.88 | 0 | 0 | 0.0037003381 | 6 | RPI - CONS | Z2 | PW | MECH | 1.3.5.30 | CONS | CONS | ZONE-4 | ROAD-3 | SEA-W |
| CON-Z4-UT-SW-NC15-97 |  | Installation of Roof Slab, Manhole Cover, Accessories & Finishes | 4d | 2017-06-01 | 2017-06-05 | CON-Z4-UT-SW-AV10-97, CON-Z4-UT-SW-NC15-96, CON-Z4-UT-SW-NC15-94 | 78d | 46.2d | Common Labor / Helper [52 h]; Finishing Work Crew [52 h] | 1,569.76 |  |  |  |  |  |  |  |  | 1.3.5.30 | CONS | CONS | ZONE-4 | ROAD-3 | SEA-W |
|  | 4 | **Wash Down Valve Chamber (WDV-11) at Road 3** |  | 2017-05-01 | 2017-08-02 |  |  |  |  |  |  |  |  |  |  |  |  |  |  |  |  |  |  |  |
| CON-Z4-UT-SW-WD11-10 |  | Excavation and Compaction | 1.6d | 2017-05-01 | 2017-05-03 | CON-Z4-UT-SW-AV10-10 | 84.4d | 0d | Operator - Excavator [26 h] | 784.88 | 0 | 0 | 0.0030836221 | 6 | RPI - CONS | Z2 | PW | MECH | 1.3.5.30 | CONS | CONS | ZONE-4 | ROAD-3 | SEA-W |
| CON-Z4-UT-SW-WD11-20 |  | Lean concrete | 0.8d | 2017-05-03 | 2017-05-03 | CON-Z4-UT-SW-WD11-10 | 84.4d | 0d | Concrete Mason [52 h]; Driver - Conc. Transit Mixers [26 h]; Operator - Concrete Pump [26 h] | 470.93 | 0 | 0 | 0.0003088871 | 6 | RPI - CONS | Z2 | PW | MECH | 1.3.5.30 | CONS | CONS | ZONE-4 | ROAD-3 | SEA-W |
| CON-Z4-UT-SW-WD11-50 |  | Formwork for Base Slab | 0.8d | 2017-05-04 | 2017-05-04 | CON-Z4-UT-SW-WD11-20 | 84.4d | 0d | Shuttering Carpenter [78 h]; Common Labor / Helper [52 h] | 784.88 | 0 | 0 | 0.000308358 | 6 | RPI - CONS | Z2 | PW | MECH | 1.3.5.30 | CONS | CONS | ZONE-4 | ROAD-3 | SEA-W |
| CON-Z4-UT-SW-WD11-30 |  | Fabrication & installation of Rebar for Base Slab | 2d | 2017-05-04 | 2017-05-07 | CON-Z4-UT-SW-WD11-50 | 84.4d | 0d | Steel Fixer [78 h] | 784.88 | 0 | 0 | 0.0015418111 | 6 | RPI - CONS | Z2 | PW | MECH | 1.3.5.30 | CONS | CONS | ZONE-4 | ROAD-3 | SEA-W |
| CON-Z4-UT-SW-WD11-40 |  | Fabrication & installation of Rebar for Side walls | 2d | 2017-05-07 | 2017-05-09 | CON-Z4-UT-SW-WD11-30 | 84.4d | 0d | Steel Fixer [78 h] | 784.88 | 0 | 0 | 0.0030836221 | 6 | RPI - CONS | Z2 | PW | MECH | 1.3.5.30 | CONS | CONS | ZONE-4 | ROAD-3 | SEA-W |
| CON-Z4-UT-SW-WD11-70 |  | Formwork for side walls | 4d | 2017-05-08 | 2017-05-13 | CON-Z4-UT-SW-WD11-40 SS+0.8d | 84.4d | 0d | Shuttering Carpenter [78 h]; Common Labor / Helper [26 h]; Scaffolder [52 h] | 1,569.76 | 0 | 0 | 0.0015418111 | 6 | RPI - CONS | Z2 | PW | MECH | 1.3.5.30 | CONS | CONS | ZONE-4 | ROAD-3 | SEA-W |
| CON-Z4-UT-SW-WD11-60 |  | Concrete pouring for base slab | 0.8d | 2017-05-13 | 2017-05-14 | CON-Z4-UT-SW-WD11-70 | 84.4d | 0d | Concrete Mason [78 h]; Common Labor / Helper [26 h]; Finishing Work Crew [52 h]; Driver - Conc. Transit Mixers [26 h]; Operator - Concrete Pump [26 h] | 784.88 | 0 | 0 | 0.0015418111 | 6 | RPI - CONS | Z2 | PW | MECH | 1.3.5.30 | CONS | CONS | ZONE-4 | ROAD-3 | SEA-W |
| CON-Z4-UT-SW-WD11-80 |  | Concrete pouring for Side Wall | 0.8d | 2017-05-14 | 2017-05-15 | CON-Z4-UT-SW-WD11-60 | 84.4d | 0d | Concrete Mason [78 h]; Common Labor / Helper [26 h]; Finishing Work Crew [52 h]; Driver - Conc. Transit Mixers [26 h]; Operator - Concrete Pump [26 h] | 1,569.76 | 0 | 0 | 0.0040086961 | 6 | RPI - CONS | Z2 | PW | MECH | 1.3.5.30 | CONS | CONS | ZONE-4 | ROAD-3 | SEA-W |
| CON-Z4-UT-SW-WD11-90 |  | Formwork removal and concrete patching | 1.6d | 2017-05-15 | 2017-05-16 | CON-Z4-UT-SW-WD11-80 | 84.4d | 0d | Shuttering Carpenter [78 h]; Scaffolder [26 h]; Finishing Work Crew [52 h] | 313.95 | 0 | 0 | 0.0015418111 | 6 | RPI - CONS | Z2 | PW | MECH | 1.3.5.30 | CONS | CONS | ZONE-4 | ROAD-3 | SEA-W |
| CON-Z4-UT-SW-WD11-92 |  | Concrete Supports | 0.8d | 2017-05-16 | 2017-05-17 | CON-Z4-UT-SW-WD11-90 | 84.4d | 0d | Shuttering Carpenter [26 h]; Concrete Mason [26 h]; Common Labor / Helper [26 h] | 470.93 | 0 | 0 | 0.000616716 | 6 | RPI - CONS | Z2 | PW | MECH | 1.3.5.30 | CONS | CONS | ZONE-4 | ROAD-3 | SEA-W |
| CON-Z4-UT-SW-WD11-91 |  | Installation of Valves / Pipe Connections / Closing of Openings | 3.2d | 2017-05-17 | 2017-05-21 | CON-Z4-UT-SW-WD11-92 | 84.4d | 0d | Shuttering Carpenter [26 h]; Concrete Mason [26 h]; Common Labor / Helper [26 h]; RTR Pipe Crew [26 h] | 3,139.52 | 0 | 0 | 0.0055505071 | 6 | RPI - CONS | Z2 | PW | MECH | 1.3.5.30 | CONS | CONS | ZONE-4 | ROAD-3 | SEA-W |
| CON-Z4-UT-SW-WD11-93 |  | Damp Proof Coating | 0.8d | 2017-05-21 | 2017-05-22 | CON-Z4-UT-SW-WD11-90, CON-Z4-UT-SW-WD11-91 | 84.4d | 0d | Painter [52 h]; Water Proofing Crew [52 h] | 313.95 | 0 | 0 | 0.0015418111 | 6 | RPI - CONS | Z2 | PW | MECH | 1.3.5.30 | CONS | CONS | ZONE-4 | ROAD-3 | SEA-W |
| CON-Z4-UT-SW-WD11-94 |  | Backfilling & Compaction | 2d | 2017-05-22 | 2017-05-24 | CON-Z4-UT-SW-WD11-93 | 84.4d | 52.6d | Common Labor / Helper [52 h]; Driver - Dump Truck [26 h]; Operator - Bobcat [26 h]; Operator - Roller-Compactor (2~10 Ton) [26 h]; Driver - Water Tanker [26 h]; Operator - JCB [26 h]; Bobcat [28 h]; Roller-Compactor (2~10 Ton) [28 h]; Roller-Compactor (25 Ton) [28 h]; Water Tanker [28 h] | 1,569.76 | 0 | 0 | 0.0037003381 | 6 | RPI - CONS | Z2 | PW | MECH | 1.3.5.30 | CONS | CONS | ZONE-4 | ROAD-3 | SEA-W |
| CON-Z4-UT-SW-WD11-95 |  | Installation of Roof Slab, Manhole Cover, Accessories & Finishes | 3d | 2017-07-30 | 2017-08-02 | CON-Z4-UT-SW-NC15-97 SS, CON-Z4-UT-SW-WD11-94, CON-Z3-UT-SW-VC-8440 SS | 31.8d | 1d | Common Labor / Helper [52 h]; Finishing Work Crew [52 h] | 2,354.64 | 0 | 0 | 0.002466885 | 6 | RPI - CONS | Z2 | PW | MECH | 1.3.5.30 | CONS | CONS | ZONE-4 | ROAD-3 | SEA-W |

Notes:
- CON-Z4-UT-SW-NC15-10: Expenses: (New Expense Item) 784.88
- CON-Z4-UT-SW-NC15-20: Expenses: (New Expense Item) 470.93
- CON-Z4-UT-SW-NC15-50: Expenses: (New Expense Item) 784.88
- CON-Z4-UT-SW-NC15-30: Expenses: (New Expense Item) 784.88
- CON-Z4-UT-SW-NC15-40: Expenses: (New Expense Item) 784.88
- CON-Z4-UT-SW-NC15-70: Expenses: (New Expense Item) 1569.76
- CON-Z4-UT-SW-NC15-60: Expenses: (New Expense Item) 784.88
- CON-Z4-UT-SW-NC15-80: Expenses: (New Expense Item) 1569.76
- CON-Z4-UT-SW-NC15-90: Expenses: (New Expense Item) 313.95
- CON-Z4-UT-SW-NC15-92: Expenses: (New Expense Item) 470.93
- CON-Z4-UT-SW-NC15-91: Expenses: (New Expense Item) 1569.76
- CON-Z4-UT-SW-NC15-95: Expenses: (New Expense Item) 784.88
- CON-Z4-UT-SW-NC15-96: Expenses: (New Expense Item) 2354.64
- CON-Z4-UT-SW-NC15-93: Expenses: (New Expense Item) 313.95
- CON-Z4-UT-SW-NC15-94: Expenses: (New Expense Item) 784.88
- CON-Z4-UT-SW-NC15-97: Expenses: (New Expense Item) 1569.76
- CON-Z4-UT-SW-WD11-10: Expenses: (New Expense Item) 784.88
- CON-Z4-UT-SW-WD11-20: Expenses: (New Expense Item) 470.93
- CON-Z4-UT-SW-WD11-50: Expenses: (New Expense Item) 784.88
- CON-Z4-UT-SW-WD11-30: Expenses: (New Expense Item) 784.88
- CON-Z4-UT-SW-WD11-40: Expenses: (New Expense Item) 784.88
- CON-Z4-UT-SW-WD11-70: Expenses: (New Expense Item) 1569.76
- CON-Z4-UT-SW-WD11-60: Expenses: (New Expense Item) 784.88
- CON-Z4-UT-SW-WD11-80: Expenses: (New Expense Item) 1569.76
- CON-Z4-UT-SW-WD11-90: Expenses: (New Expense Item) 313.95
- CON-Z4-UT-SW-WD11-92: Expenses: (New Expense Item) 470.93
- CON-Z4-UT-SW-WD11-91: Expenses: (New Expense Item) 3139.52
- CON-Z4-UT-SW-WD11-93: Expenses: (New Expense Item) 313.95
- CON-Z4-UT-SW-WD11-94: Expenses: (New Expense Item) 1569.76
- CON-Z4-UT-SW-WD11-95: Expenses: (New Expense Item) 2354.64

| ID | WBS | Activity | Duration | Start | Finish | Predecessors | Total float | Free float | Resources | Cost | RPI_P2 - BOQ ITEMS | RPI_P2 - CONSTRUCTION | RPI_P2 - PHASE | RPI_P2 - ZONES | RPI_P2 - UTILITY NETWORK | RPI_P2 - AREAS |
| --- | --- | --- | --- | --- | --- | --- | --- | --- | --- | --- | --- | --- | --- | --- | --- | --- |
|  | 4 | **Sanitary Sewer System** |  | 2017-02-02 | 2017-08-03 |  |  |  |  |  |  |  |  |  |  |  |
|  | 1 | **Gravity Sewer Lines** |  | 2017-02-02 | 2017-04-03 |  |  |  |  |  |  |  |  |  |  |  |
|  | 3 | **Gravity Line From SMH-20-R3 TO SMH-24-R3 (200mm upvc) = 360 Lm** |  | 2017-02-02 | 2017-02-28 |  |  |  |  |  |  |  |  |  |  |  |
| CON-Z4-UT-GRV-PL-010 |  | Remaining Works for Construction of Gravity Line From SMH-20-R3 TO SMH-24-R3 (200mm upvc) | 10d | 2017-02-02 | 2017-02-14 | CON-Z3-UT-GRV-PL-320 | 45.2d | 0d | Plumber [52 h]; Common Labor / Helper [78 h] | 3,981.33 | 1.3.5.40 | CONS | CONS | ZONE-4 | SEWER |  |
| CON-Z4-UT-GRV-PL-020 |  | Testing and Precommissioning | 12d | 2017-02-14 | 2017-02-28 | CON-Z4-UT-GRV-PL-010 | 137.6d | 0d | Driver - Water Tanker [26 h]; Water Tanker [28 h]; Plumber [52 h]; Common Labor / Helper [52 h]; RTR Pipe Crew [52 h] | 2,654.22 | 1.3.5.40 | CONS | CONS | ZONE-4 | SEWER |  |
|  | 2 | **Gravity Line From SMH-24-R3 TO LS#9 (250mm upvc) = 317.3 Lm** |  | 2017-02-14 | 2017-03-20 |  |  |  |  |  |  |  |  |  |  |  |
| CON-Z4-UT-GRV-PL-030 |  | Excavation of Trench (47.3 Lm) | 0.8d | 2017-02-14 | 2017-02-15 | CON-Z4-UT-GRV-PL-010 | 45.2d | 0d | Common Labor / Helper [39 h]; Operator - Excavator [13 h]; Driver - Dump Truck [13 h]; Operator - JCB [13 h]; Excavator [14 h]; Dump Truck [14 h] | 497.67 | 1.3.5.40 | CONS | CONS | ZONE-4 | SEWER |  |
| CON-Z4-UT-GRV-PL-040 |  | Compaction and Sand bedding | 1.6d | 2017-02-19 | 2017-02-20 | CON-Z4-UT-GRV-PL-030 SS+3.2d | 143.2d | 0d | Common Labor / Helper [52 h]; Operator - Loader [13 h]; Driver - Dump Truck [13 h]; Operator - Bobcat [13 h]; Operator - JCB [13 h]; Loader [14 h]; Dump Truck [14 h]; Bobcat [14 h]; JCB [14 h] | 331.78 | 1.3.5.40 | CONS | CONS | ZONE-4 | SEWER |  |
| CON-Z4-UT-GRV-PL-050 |  | Pipe Laying (47.3 Lm) | 0.8d | 2017-02-21 | 2017-02-22 | CON-Z4-UT-GRV-PL-040 SS+2.4d, PR-Z4-UT-SS-205-0080 | 143.2d | 5.6d | Plumber [52 h]; Common Labor / Helper [78 h]; RTR Pipe Crew [52 h]; Operator - Mobile Crane [26 h]; Driver - Flat Bed Trailer [26 h]; Mobile Crane ( 25-60 Ton) [28 h]; Flat Bed Trailer [28 h] | 995.33 | 1.3.5.40 | CONS | CONS | ZONE-4 | SEWER |  |
| CON-Z4-UT-GRV-PL-060 |  | Installation of Thurst Block (47.3 Lm) | 1d | 2017-02-28 | 2017-03-01 | CON-Z4-UT-GRV-PL-020, CON-Z4-UT-GRV-PL-050 | 137.6d | 0d | Steel Fixer [26 h]; Shuttering Carpenter [52 h]; Concrete Mason [52 h]; Common Labor / Helper [52 h]; Driver - Conc. Transit Mixers [26 h]; Operator - Concrete Pump [26 h]; Concrete Transit Mixers [28 h]; Concrete Pump [28 h] | 331.78 | 1.3.5.40 | CONS | CONS | ZONE-4 | SEWER |  |
| CON-Z4-UT-GRV-PL-070 |  | Backfilling | 8d | 2017-03-01 | 2017-03-11 | CON-Z4-UT-GRV-PL-060 | 137.6d | 0d | Common Labor / Helper [104 h]; Operator - Loader [26 h]; Driver - Dump Truck [26 h]; Operator - Bobcat [26 h]; Operator - Asphalt Compactor / Roller [26 h]; Operator - Roller-Compactor (2~10 Ton) [26 h]; Driver - Water Tanker [26 h]; Operator - JCB [26 h]; Loader [28 h]; Dump Truck [28 h]; Bobcat [28 h]; Roller-Compactor (2~10 Ton) [28 h]; Plate Compactor [28 h]; Vibrators [28 h]; Water Tanker [28 h]; JCB [28 h] | 497.67 | 1.3.5.40 | CONS | CONS | ZONE-4 | SEWER |  |
| CON-Z4-UT-GRV-PL-130 |  | Testing and Precommissioning | 8d | 2017-03-11 | 2017-03-20 | CON-Z4-UT-GRV-PL-020, CON-Z4-UT-GRV-PL-070 | 141.6d | 4d | Plumber [52 h]; Common Labor / Helper [52 h]; RTR Pipe Crew [52 h]; Driver - Water Tanker [26 h]; Water Tanker [28 h] | 663.55 | 1.3.5.40 | CONS | CONS | ZONE-4 | SEWER |  |
|  | 1 | **Gravity Line From SMH-18-R2 TO LS#9 (200mm upvc) = 386.3 Lm** |  | 2017-02-15 | 2017-04-03 |  |  |  |  |  |  |  |  |  |  |  |
| CON-Z4-UT-GRV-PL-080 |  | Excavation of Trench | 4d | 2017-02-15 | 2017-02-20 | CON-Z4-UT-GRV-PL-030 | 45.2d | 0d | Common Labor / Helper [39 h]; Operator - Excavator [13 h]; Driver - Dump Truck [13 h]; Operator - JCB [13 h]; Excavator [14 h]; Dump Truck [14 h] | 1,990.66 | 1.3.5.40 | CONS | CONS | ZONE-4 | SEWER |  |
| CON-Z4-UT-GRV-PL-090 |  | Compaction and Sand bedding | 4d | 2017-02-19 | 2017-02-23 | CON-Z4-UT-GRV-PL-080 SS+3.2d | 142.2d | 0d | Common Labor / Helper [104 h]; Operator - Loader [26 h]; Driver - Dump Truck [26 h]; Operator - Bobcat [26 h]; Operator - JCB [26 h]; Loader [28 h]; Dump Truck [28 h]; Bobcat [28 h]; JCB [28 h] | 1,327.11 | 1.3.5.40 | CONS | CONS | ZONE-4 | SEWER |  |
| CON-Z4-UT-GRV-PL-100 |  | Pipe Laying | 10d | 2017-02-22 | 2017-03-06 | CON-Z4-UT-GRV-PL-090 SS+2.4d | 142.2d | 0d | Plumber [65 h]; Common Labor / Helper [39 h]; RTR Pipe Crew [26 h]; Operator - Mobile Crane [13 h]; Driver - Flat Bed Trailer [13 h]; Mobile Crane ( 25-60 Ton) [14 h]; Flat Bed Trailer [14 h] | 3,981.33 | 1.3.5.40 | CONS | CONS | ZONE-4 | SEWER |  |
| CON-Z4-UT-GRV-PL-110 |  | Installation of Thurst Block | 5d | 2017-02-27 | 2017-03-05 | CON-Z4-UT-GRV-PL-100 SS+4d | 143.2d | 5.6d | Steel Fixer [26 h]; Shuttering Carpenter [52 h]; Concrete Mason [52 h]; Common Labor / Helper [52 h]; Driver - Conc. Transit Mixers [26 h]; Operator - Concrete Pump [26 h]; Concrete Transit Mixers [28 h]; Concrete Pump [28 h] | 1,327.11 | 1.3.5.40 | CONS | CONS | ZONE-4 | SEWER |  |
| CON-Z4-UT-GRV-PL-120 |  | Backfilling | 12d | 2017-03-11 | 2017-03-25 | CON-Z4-UT-GRV-PL-100, CON-Z4-UT-GRV-PL-110, CON-Z4-UT-GRV-PL-070 | 137.6d | 0d | Common Labor / Helper [104 h]; Operator - Loader [26 h]; Driver - Dump Truck [26 h]; Operator - Bobcat [26 h]; Operator - Asphalt Compactor / Roller [26 h]; Operator - Roller-Compactor (2~10 Ton) [26 h]; Driver - Water Tanker [26 h]; Operator - JCB [26 h]; Loader [28 h]; Dump Truck [28 h]; Bobcat [28 h]; Roller-Compactor (2~10 Ton) [28 h]; Plate Compactor [28 h]; Vibrators [28 h]; Water Tanker [28 h]; JCB [28 h] | 1,990.66 | 1.3.5.40 | CONS | CONS | ZONE-4 | SEWER |  |
| CON-Z4-UT-GRV-PL-140 |  | Testing and Precommissioning | 8d | 2017-03-25 | 2017-04-03 | CON-Z4-UT-GRV-PL-120, CON-Z4-UT-GRV-PL-130 | 137.6d | 92.4d | Plumber [52 h]; Common Labor / Helper [52 h]; RTR Pipe Crew [52 h]; Driver - Water Tanker [26 h]; Water Tanker [28 h] | 2,654.22 | 1.3.5.40 | CONS | CONS | ZONE-4 | SEWER |  |
|  | 3 | **Sewer Manholes** |  | 2017-02-20 | 2017-05-07 |  |  |  |  |  |  |  |  |  |  |  |
|  | 5 | **Sewer Manholes on Road 3 (From SMH-20-R3 To SMH-29-R3) - 9 No.** |  | 2017-02-20 | 2017-05-07 |  |  |  |  |  |  |  |  |  |  |  |
| CON-Z4-UT-SEW-MH-010 |  | Cleaning of Manhole | 7.2d | 2017-02-20 | 2017-02-28 | CON-Z4-UT-GRV-PL-080 | 102.6d | 0d | Common Labor / Helper [52 h] | 995.33 | 1.3.5.40 | CONS | CONS | ZONE-4 | SEWER | ROAD-3 |
| CON-Z4-UT-SEW-MH-020 |  | Benching | 7.2d | 2017-02-28 | 2017-03-08 | CON-Z4-UT-SEW-MH-010 | 102.6d | 0d | Concrete Mason [52 h]; Common Labor / Helper [26 h]; Plaster Mason [78 h]; Driver - Conc. Transit Mixers [26 h]; Operator - Concrete Pump [26 h]; Concrete Transit Mixers [28 h]; Concrete Pump [28 h]; Tower Light [28 h] | 1,493 | 1.3.5.40 | CONS | CONS | ZONE-4 | SEWER | ROAD-3 |
| CON-Z4-UT-SEW-MH-030 |  | Internal Finishing | 7.2d | 2017-03-09 | 2017-03-18 | CON-Z4-UT-SEW-MH-020 | 102.6d | 0d | Common Labor / Helper [52 h]; Finishing Work Crew [52 h] | 995.33 | 1.3.5.40 | CONS | CONS | ZONE-4 | SEWER | ROAD-3 |
| CON-Z4-UT-SEW-MH-040 |  | Internal Bitumen Coating | 7.2d | 2017-03-18 | 2017-03-26 | CON-Z4-UT-SEW-MH-030 | 102.6d | 0d | Water Proofing Crew [52 h] | 1,493 | 1.3.5.40 | CONS | CONS | ZONE-4 | SEWER | ROAD-3 |
| CON-Z4-UT-SEW-MH-050 |  | Remaining Backfilling | 14.4d | 2017-03-26 | 2017-04-11 | CON-Z4-UT-SEW-MH-040 | 102.6d | 0d | Common Labor / Helper [52 h]; Driver - Dump Truck [26 h]; Operator - Bobcat [26 h]; Driver - Water Tanker [26 h]; Operator - JCB [26 h]; Bobcat [28 h]; Roller-Compactor (2~10 Ton) [28 h]; Roller-Compactor (25 Ton) [28 h]; Water Tanker [28 h]; Operator - Roller-Compactor (2~10 Ton) [26 h] | 1,990.66 | 1.3.5.40 | CONS | CONS | ZONE-4 | SEWER | ROAD-3 |
| CON-Z4-UT-SEW-MH-060 |  | Construction of Top Concrete Slab | 14.4d | 2017-04-11 | 2017-04-29 | CON-Z4-UT-SEW-MH-050 | 102.6d | 0d | Steel Fixer [52 h]; Shuttering Carpenter [52 h]; Concrete Mason [52 h]; Common Labor / Helper [52 h]; Driver - Conc. Transit Mixers [26 h]; Operator - Concrete Pump [26 h]; Concrete Transit Mixers [28 h]; Concrete Pump [28 h] | 1,990.66 | 1.3.5.40 | CONS | CONS | ZONE-4 | SEWER | ROAD-3 |
| CON-Z4-UT-SEW-MH-070 |  | Installation of D.I Frame and Cover | 7.2d | 2017-04-29 | 2017-05-07 | CON-Z3-UT-SEW-MH-350 SS, CON-Z4-UT-SEW-MH-060 | 102.6d | 72.4d | Shuttering Carpenter [26 h]; Concrete Mason [26 h]; Common Labor / Helper [52 h] | 995.33 | 1.3.5.40 | CONS | CONS | ZONE-4 | SEWER | ROAD-3 |

Notes:
- CON-Z4-UT-GRV-PL-010: Expenses: (New Expense Item) 3981.33
- CON-Z4-UT-GRV-PL-020: Expenses: (New Expense Item) 2654.22
- CON-Z4-UT-GRV-PL-030: Expenses: (New Expense Item) 497.67
- CON-Z4-UT-GRV-PL-040: Expenses: (New Expense Item) 331.78
- CON-Z4-UT-GRV-PL-050: Expenses: (New Expense Item) 995.33
- CON-Z4-UT-GRV-PL-060: Expenses: (New Expense Item) 331.78
- CON-Z4-UT-GRV-PL-070: Expenses: (New Expense Item) 497.67
- CON-Z4-UT-GRV-PL-130: Expenses: (New Expense Item) 663.55
- CON-Z4-UT-GRV-PL-080: Expenses: (New Expense Item) 1990.66
- CON-Z4-UT-GRV-PL-090: Expenses: (New Expense Item) 1327.11
- CON-Z4-UT-GRV-PL-100: Expenses: (New Expense Item) 3981.33
- CON-Z4-UT-GRV-PL-110: Expenses: (New Expense Item) 1327.11
- CON-Z4-UT-GRV-PL-120: Expenses: (New Expense Item) 1990.66
- CON-Z4-UT-GRV-PL-140: Expenses: (New Expense Item) 2654.22
- CON-Z4-UT-SEW-MH-010: Expenses: (New Expense Item) 995.33
- CON-Z4-UT-SEW-MH-020: Expenses: (New Expense Item) 1493
- CON-Z4-UT-SEW-MH-030: Expenses: (New Expense Item) 995.33
- CON-Z4-UT-SEW-MH-040: Expenses: (New Expense Item) 1493
- CON-Z4-UT-SEW-MH-050: Expenses: (New Expense Item) 1990.66
- CON-Z4-UT-SEW-MH-060: Expenses: (New Expense Item) 1990.66
- CON-Z4-UT-SEW-MH-070: Expenses: (New Expense Item) 995.33

| ID | WBS | Activity | Duration | Start | Finish | Predecessors | Total float | Free float | Resources | Cost | RPI_P2 - BOQ ITEMS | RPI_P2 - CONSTRUCTION | RPI_P2 - PHASE | RPI_P2 - ZONES | RPI_P2 - UTILITY NETWORK | Activity Wt% | Weight % | Cost Wt | RPI - PHASE | RPI - CONSTRUCTION | RPI - ZONES | RPI - UTILITY NETWORKS | RPI - TYPE OF WORK | RPI_P2 - AREAS |
| --- | --- | --- | --- | --- | --- | --- | --- | --- | --- | --- | --- | --- | --- | --- | --- | --- | --- | --- | --- | --- | --- | --- | --- | --- |
|  | 2 | **Force Main Sewer Line** |  | 2017-04-18 | 2017-08-03 |  |  |  |  |  |  |  |  |  |  |  |  |  |  |  |  |  |  |  |
|  | 2 | **Force Main Line From SLS-9 to SDC-1 (200mm upvc) = 1123.45 Lm** |  | 2017-04-18 | 2017-08-03 |  |  |  |  |  |  |  |  |  |  |  |  |  |  |  |  |  |  |  |
| CON-Z4-UT-FM-PL-130 |  | Excavation of Trench | 10d | 2017-04-18 | 2017-04-30 | CON-Z4-UT-GRV-PL-080 FS+49d | 45.2d | 0d | Excavator [14 h]; Dump Truck [14 h]; Common Labor / Helper [39 h]; Operator - Excavator [13 h]; Driver - Dump Truck [13 h]; Operator - JCB [13 h] | 2,986 | 1.3.5.40 | CONS | CONS | ZONE-4 | SEWER |  |  |  |  |  |  |  |  |  |
| CON-Z4-UT-FM-PL-140 |  | Compaction and Sand bedding | 10d | 2017-04-22 | 2017-05-03 | CON-Z4-UT-FM-PL-130 SS+3.2d | 45.2d | 0d | Common Labor / Helper [104 h]; Operator - Loader [26 h]; Driver - Dump Truck [26 h]; Operator - Bobcat [26 h]; Operator - JCB [26 h]; Loader [28 h]; Dump Truck [28 h]; Bobcat [28 h]; JCB [28 h] | 1,990.66 | 1.3.5.40 | CONS | CONS | ZONE-4 | SEWER |  |  |  |  |  |  |  |  |  |
| CON-Z4-UT-FM-PL-150 |  | Pipe Laying | 28d | 2017-04-25 | 2017-05-28 | CON-Z4-UT-FM-PL-140 SS+2.4d | 45.2d | 0d | Plumber [52 h]; Common Labor / Helper [78 h]; RTR Pipe Crew [52 h]; Operator - Mobile Crane [26 h]; Driver - Flat Bed Trailer [26 h]; Mobile Crane ( 25-60 Ton) [28 h]; Flat Bed Trailer [28 h] | 5,971.99 | 1.3.5.40 | CONS | CONS | ZONE-4 | SEWER |  |  |  |  |  |  |  |  |  |
| CON-Z4-UT-FM-PL-160 |  | Installation of Thurst Block | 20d | 2017-04-30 | 2017-05-23 | CON-Z4-UT-FM-PL-150 SS+4d | 49.2d | 4d | Steel Fixer [26 h]; Shuttering Carpenter [52 h]; Concrete Mason [52 h]; Common Labor / Helper [52 h]; Driver - Conc. Transit Mixers [26 h]; Operator - Concrete Pump [26 h]; Concrete Transit Mixers [28 h]; Concrete Pump [28 h] | 1,990.66 | 1.3.5.40 | CONS | CONS | ZONE-4 | SEWER |  |  |  |  |  |  |  |  |  |
| CON-Z4-UT-FM-PL-170 |  | Backfilling | 38d | 2017-05-28 | 2017-07-16 | CON-Z4-UT-FM-PL-150, CON-Z4-UT-FM-PL-160 | 45.2d | 0d | Common Labor / Helper [52 h]; Operator - Loader [13 h]; Driver - Dump Truck [13 h]; Operator - Bobcat [13 h]; Operator - Asphalt Compactor / Roller [13 h]; Operator - Roller-Compactor (2~10 Ton) [13 h]; Driver - Water Tanker [13 h]; Operator - JCB [13 h]; Loader [14 h]; Dump Truck [14 h]; Bobcat [14 h]; Roller-Compactor (2~10 Ton) [14 h]; Plate Compactor [14 h]; Vibrators [14 h]; Water Tanker [14 h]; JCB [14 h] | 2,986 | 1.3.5.40 | CONS | CONS | ZONE-4 | SEWER |  |  |  |  |  |  |  |  |  |
| CON-Z4-UT-FM-PL-230 |  | Testing and Precommissioning | 16d | 2017-07-16 | 2017-08-03 | CON-Z4-UT-FM-PL-170, CON-Z4-UT-GRV-PL-140 SS | 45.2d | 0d | Plumber [52 h]; Common Labor / Helper [52 h]; RTR Pipe Crew [52 h]; Driver - Water Tanker [160 h]; Water Tanker [224 h] | 3,981.33 | 1.3.5.40 | CONS | CONS | ZONE-4 | SEWER |  |  |  |  |  |  |  |  |  |
|  | 1 | **Force Main Line From SDC-1 To SMH-19-R-3(250mm upvc) = 10 Lm** |  | 2017-04-30 | 2017-07-17 |  |  |  |  |  |  |  |  |  |  |  |  |  |  |  |  |  |  |  |
| CON-Z4-UT-FM-PL-180 |  | Excavation of Trench | 0.8d | 2017-04-30 | 2017-05-01 | CON-Z4-UT-FM-PL-130 | 73.2d | 0d | Common Labor / Helper [39 h]; Operator - Excavator [13 h]; Driver - Dump Truck [13 h]; Operator - JCB [13 h]; Excavator [14 h]; Dump Truck [14 h] | 497.67 | 1.3.5.40 | CONS | CONS | ZONE-4 | SEWER |  |  |  |  |  |  |  |  |  |
| CON-Z4-UT-FM-PL-190 |  | Compaction and Sand bedding | 0.8d | 2017-05-03 | 2017-05-04 | CON-Z4-UT-FM-PL-180 SS+3.2d | 94.2d | 0d | Common Labor / Helper [52 h]; Operator - Loader [13 h]; Driver - Dump Truck [13 h]; Operator - Bobcat [13 h]; Operator - JCB [13 h]; Loader [14 h]; Dump Truck [14 h]; Bobcat [14 h]; JCB [14 h] | 331.78 | 1.3.5.40 | CONS | CONS | ZONE-4 | SEWER |  |  |  |  |  |  |  |  |  |
| CON-Z4-UT-FM-PL-200 |  | Pipe Laying | 0.8d | 2017-05-07 | 2017-05-07 | CON-Z4-UT-FM-PL-190 SS+2.4d | 94.2d | 0d | Plumber [65 h]; Common Labor / Helper [39 h]; RTR Pipe Crew [26 h]; Operator - Mobile Crane [13 h]; Driver - Flat Bed Trailer [13 h]; Mobile Crane ( 25-60 Ton) [14 h]; Flat Bed Trailer [14 h] | 995.33 | 1.3.5.40 | CONS | CONS | ZONE-4 | SEWER |  |  |  |  |  |  |  |  |  |
| CON-Z4-UT-FM-PL-210 |  | Backfilling | 3d | 2017-05-11 | 2017-05-15 | CON-Z4-UT-FM-PL-200 SS+4d | 94.2d | 49d | Common Labor / Helper [52 h]; Operator - Loader [13 h]; Driver - Dump Truck [13 h]; Operator - Bobcat [13 h]; Operator - Asphalt Compactor / Roller [13 h]; Operator - Roller-Compactor (2~10 Ton) [13 h]; Driver - Water Tanker [13 h]; Operator - JCB [13 h]; Loader [14 h]; Dump Truck [14 h]; Bobcat [14 h]; Roller-Compactor (2~10 Ton) [14 h]; Plate Compactor [14 h]; Vibrators [14 h]; Water Tanker [14 h]; JCB [14 h] | 663.55 | 1.3.5.40 | CONS | CONS | ZONE-4 | SEWER |  |  |  |  |  |  |  |  |  |
| CON-Z4-UT-FM-PL-220 |  | Testing and Precommissioning | 1.6d | 2017-07-16 | 2017-07-17 | CON-Z4-UT-FM-PL-210, CON-Z4-UT-FM-PL-200, CON-Z4-UT-FM-PL-230 SS | 45.2d | 15d | Plumber [52 h]; Common Labor / Helper [52 h]; RTR Pipe Crew [52 h]; Driver - Water Tanker [26 h]; Water Tanker [28 h] | 829.44 | 1.3.5.40 | CONS | CONS | ZONE-4 | SEWER |  |  |  |  |  |  |  |  |  |
|  | 4 | **Sanitary Sewer Chambers** |  | 2017-05-01 | 2017-06-10 |  |  |  |  |  |  |  |  |  |  |  |  |  |  |  |  |  |  |  |
|  | 3 | **Air Release Valve Chamber (AV-1) at Road 3** |  | 2017-05-01 | 2017-06-10 |  |  |  |  |  |  |  |  |  |  |  |  |  |  |  |  |  |  |  |
| CON-Z4-UT-SS-VC-0010 |  | Excavation and Compaction | 1.6d | 2017-05-01 | 2017-05-02 | CON-Z4-UT-FM-PL-180 | 73.2d | 0d | Operator - Excavator [26 h] | 497.67 | 1.3.5.40 | CONS | CONS | ZONE-4 | SEWER | 0 | 0 | 0.0030836221 | 6 | RPI - CONS | Z2 | PW | MECH | ROAD-3 |
| CON-Z4-UT-SS-VC-0020 |  | Lean concrete | 0.8d | 2017-05-03 | 2017-05-03 | CON-Z4-UT-SS-VC-0010 | 73.2d | 0d | Concrete Mason [52 h]; Driver - Conc. Transit Mixers [26 h]; Operator - Concrete Pump [26 h] | 298.6 | 1.3.5.40 | CONS | CONS | ZONE-4 | SEWER | 0 | 0 | 0.0003088871 | 6 | RPI - CONS | Z2 | PW | MECH | ROAD-3 |
| CON-Z4-UT-SS-VC-0050 |  | Formwork for Base Slab | 0.8d | 2017-05-03 | 2017-05-04 | CON-Z4-UT-SS-VC-0020 | 73.2d | 0d | Shuttering Carpenter [78 h]; Common Labor / Helper [52 h] | 497.67 | 1.3.5.40 | CONS | CONS | ZONE-4 | SEWER | 0 | 0 | 0.000308358 | 6 | RPI - CONS | Z2 | PW | MECH | ROAD-3 |
| CON-Z4-UT-SS-VC-0030 |  | Fabrication & installation of Rebar for Base Slab | 4d | 2017-05-04 | 2017-05-09 | CON-Z4-UT-SS-VC-0050 | 73.2d | 0d | Steel Fixer [78 h] | 497.67 | 1.3.5.40 | CONS | CONS | ZONE-4 | SEWER | 0 | 0 | 0.0015418111 | 6 | RPI - CONS | Z2 | PW | MECH | ROAD-3 |
| CON-Z4-UT-SS-VC-0040 |  | Fabrication & installation of Rebar for Side walls | 4d | 2017-05-09 | 2017-05-14 | CON-Z4-UT-SS-VC-0030 | 73.2d | 0d | Steel Fixer [78 h] | 497.67 | 1.3.5.40 | CONS | CONS | ZONE-4 | SEWER | 0 | 0 | 0.0030836221 | 6 | RPI - CONS | Z2 | PW | MECH | ROAD-3 |
| CON-Z4-UT-SS-VC-0070 |  | Formwork for side walls | 4d | 2017-05-10 | 2017-05-15 | CON-Z4-UT-SS-VC-0040 SS+0.8d | 73.2d | 0d | Shuttering Carpenter [78 h]; Common Labor / Helper [26 h]; Scaffolder [52 h] | 995.33 | 1.3.5.40 | CONS | CONS | ZONE-4 | SEWER | 0 | 0 | 0.0015418111 | 6 | RPI - CONS | Z2 | PW | MECH | ROAD-3 |
| CON-Z4-UT-SS-VC-0060 |  | Concrete pouring for base slab | 0.8d | 2017-05-15 | 2017-05-16 | CON-Z4-UT-SS-VC-0070 | 73.2d | 0d | Concrete Mason [78 h]; Common Labor / Helper [26 h]; Finishing Work Crew [52 h]; Driver - Conc. Transit Mixers [26 h]; Operator - Concrete Pump [26 h] | 497.67 | 1.3.5.40 | CONS | CONS | ZONE-4 | SEWER | 0 | 0 | 0.0015418111 | 6 | RPI - CONS | Z2 | PW | MECH | ROAD-3 |
| CON-Z4-UT-SS-VC-0080 |  | Concrete pouring for Side Wall | 0.8d | 2017-05-16 | 2017-05-16 | CON-Z4-UT-SS-VC-0060 | 73.2d | 0d | Concrete Mason [78 h]; Common Labor / Helper [26 h]; Finishing Work Crew [52 h]; Driver - Conc. Transit Mixers [26 h]; Operator - Concrete Pump [26 h] | 995.33 | 1.3.5.40 | CONS | CONS | ZONE-4 | SEWER | 0 | 0 | 0.0040086961 | 6 | RPI - CONS | Z2 | PW | MECH | ROAD-3 |
| CON-Z4-UT-SS-VC-0090 |  | Formwork removal and concrete patching | 1.6d | 2017-05-17 | 2017-05-18 | CON-Z4-UT-SS-VC-0080 | 73.2d | 0d | Shuttering Carpenter [78 h]; Scaffolder [26 h]; Finishing Work Crew [52 h] | 199.07 | 1.3.5.40 | CONS | CONS | ZONE-4 | SEWER | 0 | 0 | 0.0015418111 | 6 | RPI - CONS | Z2 | PW | MECH | ROAD-3 |
| CON-Z4-UT-SS-VC-0100 |  | Concrete Supports | 0.8d | 2017-05-18 | 2017-05-20 | CON-Z4-UT-SS-VC-0090 | 73.2d | 0d | Shuttering Carpenter [26 h]; Concrete Mason [26 h]; Common Labor / Helper [26 h] | 1,990.66 | 1.3.5.40 | CONS | CONS | ZONE-4 | SEWER | 0 | 0 | 0.000616716 | 6 | RPI - CONS | Z2 | PW | MECH | ROAD-3 |
| CON-Z4-UT-SS-VC-0110 |  | Installation of Valves / Pipe Connections / Closing of Openings | 3.2d | 2017-05-20 | 2017-05-23 | CON-Z4-UT-SS-VC-0100 | 73.2d | 0d | Shuttering Carpenter [26 h]; Concrete Mason [26 h]; Common Labor / Helper [26 h]; RTR Pipe Crew [26 h] | 298.6 | 1.3.5.40 | CONS | CONS | ZONE-4 | SEWER | 0 | 0 | 0.0055505071 | 6 | RPI - CONS | Z2 | PW | MECH | ROAD-3 |
| CON-Z4-UT-SS-VC-0120 |  | Damp Proof Coating | 0.8d | 2017-05-23 | 2017-05-24 | CON-Z4-UT-SS-VC-0110, CON-Z4-UT-SS-VC-0090 | 73.2d | 0d | Painter [52 h]; Water Proofing Crew [52 h] | 199.07 | 1.3.5.40 | CONS | CONS | ZONE-4 | SEWER | 0 | 0 | 0.0015418111 | 6 | RPI - CONS | Z2 | PW | MECH | ROAD-3 |
| CON-Z4-UT-SS-VC-0130 |  | Backfilling & Compaction | 4d | 2017-05-24 | 2017-05-29 | CON-Z4-UT-SS-VC-0120 | 73.2d | 0d | Roller-Compactor (2~10 Ton) [28 h]; Roller-Compactor (25 Ton) [28 h]; Water Tanker [28 h]; Common Labor / Helper [52 h]; Driver - Dump Truck [26 h]; Operator - Bobcat [26 h]; Operator - Roller-Compactor (2~10 Ton) [26 h]; Driver - Water Tanker [26 h]; Operator - JCB [26 h]; Bobcat [28 h] | 995.33 | 1.3.5.40 | CONS | CONS | ZONE-4 | SEWER | 0 | 0 | 0.0037003381 | 6 | RPI - CONS | Z2 | PW | MECH | ROAD-3 |
| CON-Z4-UT-SS-VC-0140 |  | Installation of Roof Slab, Manhole Cover, Accessories & Finishes | 5.6d | 2017-06-04 | 2017-06-10 | CON-Z4-UT-SS-VC-0130 FS+4.8d | 73.2d | 43d | Common Labor / Helper [52 h]; Finishing Work Crew [52 h] | 1,493 | 1.3.5.40 | CONS | CONS | ZONE-4 | SEWER | 0 | 0 | 0.002466885 | 6 | RPI - CONS | Z2 | PW | MECH | ROAD-3 |

Notes:
- CON-Z4-UT-FM-PL-130: Expenses: (New Expense Item) 2986
- CON-Z4-UT-FM-PL-140: Expenses: (New Expense Item) 1990.66
- CON-Z4-UT-FM-PL-150: Expenses: (New Expense Item) 5971.99
- CON-Z4-UT-FM-PL-160: Expenses: (New Expense Item) 1990.66
- CON-Z4-UT-FM-PL-170: Expenses: (New Expense Item) 2986
- CON-Z4-UT-FM-PL-230: Expenses: (New Expense Item) 3981.33
- CON-Z4-UT-FM-PL-180: Expenses: (New Expense Item) 497.67
- CON-Z4-UT-FM-PL-190: Expenses: (New Expense Item) 331.78
- CON-Z4-UT-FM-PL-200: Expenses: (New Expense Item) 995.33
- CON-Z4-UT-FM-PL-210: Expenses: (New Expense Item) 663.55
- CON-Z4-UT-FM-PL-220: Expenses: (New Expense Item) 829.44
- CON-Z4-UT-SS-VC-0010: Expenses: (New Expense Item) 497.67
- CON-Z4-UT-SS-VC-0020: Expenses: (New Expense Item) 298.6
- CON-Z4-UT-SS-VC-0050: Expenses: (New Expense Item) 497.67
- CON-Z4-UT-SS-VC-0030: Expenses: (New Expense Item) 497.67
- CON-Z4-UT-SS-VC-0040: Expenses: (New Expense Item) 497.67
- CON-Z4-UT-SS-VC-0070: Expenses: (New Expense Item) 995.33
- CON-Z4-UT-SS-VC-0060: Expenses: (New Expense Item) 497.67
- CON-Z4-UT-SS-VC-0080: Expenses: (New Expense Item) 995.33
- CON-Z4-UT-SS-VC-0090: Expenses: (New Expense Item) 199.07
- CON-Z4-UT-SS-VC-0100: Expenses: (New Expense Item) 1990.66
- CON-Z4-UT-SS-VC-0110: Expenses: (New Expense Item) 298.6
- CON-Z4-UT-SS-VC-0120: Expenses: (New Expense Item) 199.07
- CON-Z4-UT-SS-VC-0130: Expenses: (New Expense Item) 995.33
- CON-Z4-UT-SS-VC-0140: Expenses: (New Expense Item) 1493

| ID | WBS | Activity | Duration | Start | Finish | Predecessors | Total float | Free float | Resources | Cost | RPI_P2 - BOQ ITEMS | RPI_P2 - CONSTRUCTION | RPI_P2 - PHASE | RPI_P2 - ZONES | RPI_P2 - AREAS | RPI_P2 - UTILITY NETWORK |
| --- | --- | --- | --- | --- | --- | --- | --- | --- | --- | --- | --- | --- | --- | --- | --- | --- |
|  | 5 | **Irrigation Water System** |  | 2017-05-25 | 2017-08-24 |  |  |  |  |  |  |  |  |  |  |  |
|  | 1 | **Irrigation Pipe Line** |  | 2017-05-25 | 2017-08-24 |  |  |  |  |  |  |  |  |  |  |  |
|  | 5 | **Irrigation Line - Upvc 200mm dia at Road E= 25 Lm** |  | 2017-05-25 | 2017-06-13 |  |  |  |  |  |  |  |  |  |  |  |
| CON-Z4-UT-IRG-PL-010 |  | Excavation of Trench | 0.8d | 2017-05-25 | 2017-05-27 | CON-Z3-UT-IRG-PL-300 | 41.8d | 0d | Common Labor / Helper [39 h]; Operator - Excavator [13 h]; Driver - Dump Truck [13 h]; Operator - JCB [13 h]; Excavator [14 h]; Dump Truck [14 h] | 279.28 | 1.3.5.50 | CONS | CONS | ZONE-4 | ROAD-E | IRR |
| CON-Z4-UT-IRG-PL-020 |  | Compaction and Sand bedding | 0.8d | 2017-05-29 | 2017-05-30 | CON-Z4-UT-IRG-PL-010 SS+3.2d | 85.2d | 0d | Common Labor / Helper [52 h]; Operator - Loader [13 h]; Driver - Dump Truck [13 h]; Operator - Bobcat [13 h]; Operator - JCB [13 h]; Loader [14 h]; Dump Truck [14 h]; Bobcat [14 h]; JCB [14 h] | 186.18 | 1.3.5.50 | CONS | CONS | ZONE-4 | ROAD-E | IRR |
| CON-Z4-UT-IRG-PL-030 |  | Pipe Laying | 0.8d | 2017-06-01 | 2017-06-01 | PR-Z4-UT-IR-206-0080, CON-Z4-UT-IRG-PL-020 SS+2.4d | 85.2d | 0d | Plumber [16 h]; Common Labor / Helper [8 h]; RTR Pipe Crew [26 h]; Operator - Mobile Crane [13 h]; Driver - Flat Bed Trailer [13 h]; Mobile Crane ( 25-60 Ton) [14 h]; Flat Bed Trailer [14 h] | 558.55 | 1.3.5.50 | CONS | CONS | ZONE-4 | ROAD-E | IRR |
| CON-Z4-UT-IRG-PL-040 |  | Installation of Thurst Block | 1d | 2017-06-06 | 2017-06-07 | CON-Z4-UT-IRG-PL-030 SS+4d | 85.2d | 0d | Steel Fixer [26 h]; Shuttering Carpenter [52 h]; Concrete Mason [20 h]; Common Labor / Helper [10 h]; Driver - Conc. Transit Mixers [26 h]; Operator - Concrete Pump [26 h]; Concrete Transit Mixers [28 h]; Concrete Pump [28 h] | 186.18 | 1.3.5.50 | CONS | CONS | ZONE-4 | ROAD-E | IRR |
| CON-Z4-UT-IRG-PL-050 |  | Backfilling | 1.6d | 2017-06-07 | 2017-06-08 | CON-Z4-UT-IRG-PL-040, CON-Z4-UT-IRG-PL-030 | 85.2d | 0d | Common Labor / Helper [16 h]; Operator - Loader [13 h]; Driver - Dump Truck [13 h]; Operator - Bobcat [13 h]; Operator - Asphalt Compactor / Roller [13 h]; Operator - Roller-Compactor (2~10 Ton) [13 h]; Driver - Water Tanker [13 h]; Operator - JCB [13 h]; Loader [14 h]; Dump Truck [14 h]; Bobcat [14 h]; Roller-Compactor (2~10 Ton) [14 h]; Plate Compactor [14 h]; Vibrators [14 h]; Water Tanker [14 h]; JCB [14 h] | 279.28 | 1.3.5.50 | CONS | CONS | ZONE-4 | ROAD-E | IRR |
| CON-Z4-UT-IRG-PL-110 |  | Testing and Precommissioning | 4d | 2017-06-08 | 2017-06-13 | CON-Z4-UT-IRG-PL-050 | 85.2d | 36.8d | Plumber [52 h]; Common Labor / Helper [52 h]; RTR Pipe Crew [52 h]; Driver - Water Tanker [26 h]; Water Tanker [28 h] | 372.37 | 1.3.5.50 | CONS | CONS | ZONE-4 | ROAD-E | IRR |
|  | 1 | **Irrigation Line - Upvc 200mm dia at Road 3= 880 Lm** |  | 2017-06-01 | 2017-08-14 |  |  |  |  |  |  |  |  |  |  |  |
| CON-Z4-UT-IRG-PL-060 |  | Excavation of Trench | 5.6d | 2017-06-01 | 2017-06-07 | CON-Z4-UT-IRG-PL-010 FS+5d | 41.8d | 0d | Common Labor / Helper [26 h]; Operator - Excavator [26 h]; Driver - Dump Truck [26 h]; Operator - JCB [26 h]; Excavator [28 h]; Dump Truck [28 h] | 1,954.93 | 1.3.5.50 | CONS | CONS | ZONE-4 | ROAD-3 | IRR |
| CON-Z4-UT-IRG-PL-070 |  | Compaction and Sand bedding | 2.4d | 2017-06-05 | 2017-06-07 | CON-Z4-UT-IRG-PL-060 SS+3.2d | 48.4d | 0d | Common Labor / Helper [24 h]; Operator - Loader [156 h]; Driver - Dump Truck [156 h]; Operator - Bobcat [156 h]; Operator - JCB [156 h]; Loader [168 h]; Dump Truck [168 h]; Bobcat [168 h]; JCB [168 h] | 1,303.28 | 1.3.5.50 | CONS | CONS | ZONE-4 | ROAD-3 | IRR |
| CON-Z4-UT-IRG-PL-080 |  | Pipe Laying | 17.6d | 2017-06-08 | 2017-07-03 | CON-Z4-UT-IRG-PL-070 SS+2.4d | 48.4d | 0d | Plumber [52 h]; Common Labor / Helper [78 h]; RTR Pipe Crew [52 h]; Operator - Mobile Crane [26 h]; Driver - Flat Bed Trailer [26 h]; Mobile Crane ( 25-60 Ton) [28 h]; Flat Bed Trailer [28 h] | 3,909.85 | 1.3.5.50 | CONS | CONS | ZONE-4 | ROAD-3 | IRR |
| CON-Z4-UT-IRG-PL-090 |  | Installation of Thurst Block | 10d | 2017-06-13 | 2017-06-24 | CON-Z4-UT-IRG-PL-080 SS+4d | 52d | 3.6d | Steel Fixer [26 h]; Shuttering Carpenter [52 h]; Concrete Mason [52 h]; Common Labor / Helper [52 h]; Driver - Conc. Transit Mixers [26 h]; Operator - Concrete Pump [26 h]; Concrete Transit Mixers [28 h]; Concrete Pump [28 h] | 1,303.28 | 1.3.5.50 | CONS | CONS | ZONE-4 | ROAD-3 | IRR |
| CON-Z4-UT-IRG-PL-100 |  | Backfilling | 24d | 2017-07-03 | 2017-07-31 | CON-Z4-UT-IRG-PL-080, CON-Z4-UT-IRG-PL-090 | 48.4d | 0d | Common Labor / Helper [240 h]; Operator - Loader [240 h]; Driver - Dump Truck [240 h]; Operator - Bobcat [480 h]; Operator - Asphalt Compactor / Roller [240 h]; Operator - Roller-Compactor (2~10 Ton) [240 h]; Driver - Water Tanker [240 h]; Operator - JCB [240 h]; Loader [336 h]; Dump Truck [336 h]; Bobcat [672 h]; Roller-Compactor (2~10 Ton) [336 h]; Plate Compactor [336 h]; Vibrators [336 h]; Water Tanker [336 h]; JCB [336 h] | 1,954.93 | 1.3.5.50 | CONS | CONS | ZONE-4 | ROAD-3 | IRR |
| CON-Z4-UT-IRG-PL-120 |  | Testing and Precommissioning | 12d | 2017-07-31 | 2017-08-14 | CON-Z4-UT-IRG-PL-110, CON-Z4-UT-IRG-PL-100 | 48.4d | 13.6d | Plumber [52 h]; Common Labor / Helper [52 h]; RTR Pipe Crew [52 h]; Driver - Water Tanker [26 h]; Water Tanker [28 h] | 2,606.57 | 1.3.5.50 | CONS | CONS | ZONE-4 | ROAD-3 | IRR |
|  | 2 | **Irrigation Secondary and Laterla Lines t Road E and Road 3** |  | 2017-06-08 | 2017-08-21 |  |  |  |  |  |  |  |  |  |  |  |
| CON-Z4-UT-IRG-PL-130 |  | Excavation of Trench | 5.6d | 2017-06-08 | 2017-06-14 | CON-Z4-UT-IRG-PL-060 | 41.8d | 0d | Common Labor / Helper [26 h]; Operator - Excavator [26 h]; Driver - Dump Truck [26 h]; Operator - JCB [26 h]; Excavator [28 h]; Dump Truck [28 h] | 1,396.38 | 1.3.5.50 | CONS | CONS | ZONE-4 | ROAD-E | IRR |
| CON-Z4-UT-IRG-PL-140 |  | Compaction and Sand bedding | 2.4d | 2017-06-12 | 2017-06-14 | CON-Z4-UT-IRG-PL-130 SS+3.2d | 41.8d | 0d | Common Labor / Helper [24 h]; Operator - Loader [26 h]; Driver - Dump Truck [26 h]; Operator - Bobcat [26 h]; Operator - JCB [26 h]; Loader [28 h]; Dump Truck [28 h]; Bobcat [28 h]; JCB [28 h] | 930.92 | 1.3.5.50 | CONS | CONS | ZONE-4 | ROAD-E | IRR |
| CON-Z4-UT-IRG-PL-150 |  | Pipe Laying | 17.6d | 2017-06-14 | 2017-07-10 | CON-Z4-UT-IRG-PL-140 SS+2.4d | 41.8d | 0d | Operator - Mobile Crane [26 h]; Driver - Flat Bed Trailer [26 h]; Mobile Crane ( 25-60 Ton) [28 h]; Flat Bed Trailer [28 h]; Plumber [52 h]; Common Labor / Helper [78 h]; RTR Pipe Crew [52 h] | 2,792.75 | 1.3.5.50 | CONS | CONS | ZONE-4 | ROAD-E | IRR |
| CON-Z4-UT-IRG-PL-160 |  | Installation of Thurst Block | 10d | 2017-06-19 | 2017-07-05 | CON-Z4-UT-IRG-PL-150 SS+4d | 45.4d | 3.6d | Steel Fixer [26 h]; Shuttering Carpenter [52 h]; Concrete Mason [52 h]; Common Labor / Helper [52 h]; Driver - Conc. Transit Mixers [26 h]; Operator - Concrete Pump [26 h]; Concrete Transit Mixers [28 h]; Concrete Pump [28 h] | 930.92 | 1.3.5.50 | CONS | CONS | ZONE-4 | ROAD-E | IRR |
| CON-Z4-UT-IRG-PL-170 |  | Backfilling | 24d | 2017-07-10 | 2017-08-07 | CON-Z4-UT-IRG-PL-160, CON-Z4-UT-IRG-PL-150 | 41.8d | 0d | Common Labor / Helper [104 h]; Operator - Loader [26 h]; Driver - Dump Truck [26 h]; Operator - Bobcat [26 h]; Operator - Asphalt Compactor / Roller [26 h]; Operator - Roller-Compactor (2~10 Ton) [26 h]; Driver - Water Tanker [26 h]; Operator - JCB [26 h]; Loader [28 h]; Dump Truck [28 h]; Bobcat [28 h]; Roller-Compactor (2~10 Ton) [28 h]; Plate Compactor [28 h]; Vibrators [28 h]; Water Tanker [28 h]; JCB [28 h] | 1,396.38 | 1.3.5.50 | CONS | CONS | ZONE-4 | ROAD-E | IRR |
| CON-Z4-UT-IRG-PL-180 |  | Testing and Precommissioning | 12d | 2017-08-07 | 2017-08-21 | CON-Z4-UT-IRG-PL-170 | 41.8d | 2d | Plumber [52 h]; Common Labor / Helper [52 h]; RTR Pipe Crew [52 h]; Driver - Water Tanker [26 h]; Water Tanker [28 h] | 1,861.84 | 1.3.5.50 | CONS | CONS | ZONE-4 | ROAD-E | IRR |
|  | 8 | **Irrigation Equipments** |  | 2017-07-26 | 2017-08-23 |  |  |  |  |  |  |  |  |  |  |  |
| CON-Z4-UT-IRG-PL-190 |  | Installation of Rainbird Solenoid Valve, 100-PEB | 8d | 2017-07-26 | 2017-08-05 | CON-Z3-UT-IRG-PL-350 SS, CON-Z4-UT-IRG-PL-130 | 39.8d | 0d | Plumber [52 h]; Common Labor / Helper [52 h] | 1,861.84 | 1.3.5.50 | CONS | CONS | ZONE-4 |  | IRR |
| CON-Z4-UT-IRG-PL-200 |  | Installation of Rainbird Solenoid Valve, 150-PEB | 8d | 2017-07-29 | 2017-08-07 | CON-Z4-UT-IRG-PL-190 SS+2.4d | 39.8d | 0d | Plumber [52 h]; Common Labor / Helper [52 h] | 1,861.84 | 1.3.5.50 | CONS | CONS | ZONE-4 |  | IRR |
| CON-Z4-UT-IRG-PL-210 |  | Installation of Rainbird Solenoid Valve, 200-PEB | 8d | 2017-08-01 | 2017-08-09 | CON-Z4-UT-IRG-PL-200 SS+2.4d | 39.8d | 0d | Plumber [52 h]; Common Labor / Helper [52 h] | 1,861.84 | 1.3.5.50 | CONS | CONS | ZONE-4 |  | IRR |
| CON-Z4-UT-IRG-PL-220 |  | Installation of Rainbird PRS-Dial with Pressure Indicating Carting | 8d | 2017-08-03 | 2017-08-13 | CON-Z4-UT-IRG-PL-210 SS+2.4d | 39.8d | 0d | Plumber [52 h]; Common Labor / Helper [52 h] | 930.92 | 1.3.5.50 | CONS | CONS | ZONE-4 |  | IRR |
| CON-Z4-UT-IRG-PL-230 |  | Installation of Rainbird XCZ-PRB-100-com series solenoid valve assembly | 12d | 2017-08-06 | 2017-08-20 | CON-Z4-UT-IRG-PL-220 SS+2.4d | 39.8d | 0d | Plumber [52 h]; Common Labor / Helper [52 h] | 930.92 | 1.3.5.50 | CONS | CONS | ZONE-4 |  | IRR |
| CON-Z4-UT-IRG-PL-240 |  | Installation of Rainbird XCZ-PRB-150-com series solenoid valve assembly | 12d | 2017-08-09 | 2017-08-23 | CON-Z4-UT-IRG-PL-230 SS+2.4d | 39.8d | 0d | Plumber [52 h]; Common Labor / Helper [52 h] | 930.92 | 1.3.5.50 | CONS | CONS | ZONE-4 |  | IRR |
| CON-Z4-UT-IRG-PL-320 |  | Installation of Burried Gate Valves | 4d | 2017-08-09 | 2017-08-14 | CON-Z3-UT-IRG-PL-510 SS, CON-Z4-UT-IRG-PL-240 SS | 39.8d | 0d | Plumber [52 h]; Common Labor / Helper [52 h] | 930.92 | 1.3.5.50 | CONS | CONS | ZONE-4 |  | IRR |

Notes:
- CON-Z4-UT-IRG-PL-010: Expenses: (New Expense Item) 279.28
- CON-Z4-UT-IRG-PL-020: Expenses: (New Expense Item) 186.18
- CON-Z4-UT-IRG-PL-030: Expenses: (New Expense Item) 558.55
- CON-Z4-UT-IRG-PL-040: Expenses: (New Expense Item) 186.18
- CON-Z4-UT-IRG-PL-050: Expenses: (New Expense Item) 279.28
- CON-Z4-UT-IRG-PL-110: Expenses: (New Expense Item) 372.37
- CON-Z4-UT-IRG-PL-060: Expenses: (New Expense Item) 1954.93
- CON-Z4-UT-IRG-PL-070: Expenses: (New Expense Item) 1303.28
- CON-Z4-UT-IRG-PL-080: Expenses: (New Expense Item) 3909.85
- CON-Z4-UT-IRG-PL-090: Expenses: (New Expense Item) 1303.28
- CON-Z4-UT-IRG-PL-100: Expenses: (New Expense Item) 1954.93
- CON-Z4-UT-IRG-PL-120: Expenses: (New Expense Item) 2606.57
- CON-Z4-UT-IRG-PL-130: Expenses: (New Expense Item) 1396.38
- CON-Z4-UT-IRG-PL-140: Expenses: (New Expense Item) 930.92
- CON-Z4-UT-IRG-PL-150: Expenses: (New Expense Item) 2792.75
- CON-Z4-UT-IRG-PL-160: Expenses: (New Expense Item) 930.92
- CON-Z4-UT-IRG-PL-170: Expenses: (New Expense Item) 1396.38
- CON-Z4-UT-IRG-PL-180: Expenses: (New Expense Item) 1861.84
- CON-Z4-UT-IRG-PL-190: Expenses: (New Expense Item) 1861.84
- CON-Z4-UT-IRG-PL-200: Expenses: (New Expense Item) 1861.84
- CON-Z4-UT-IRG-PL-210: Expenses: (New Expense Item) 1861.84
- CON-Z4-UT-IRG-PL-220: Expenses: (New Expense Item) 930.92
- CON-Z4-UT-IRG-PL-230: Expenses: (New Expense Item) 930.92
- CON-Z4-UT-IRG-PL-240: Expenses: (New Expense Item) 930.92
- CON-Z4-UT-IRG-PL-320: Expenses: (New Expense Item) 930.92

| ID | WBS | Activity | Duration | Start | Finish | Predecessors | Total float | Free float | Resources | Cost | RPI_P2 - BOQ ITEMS | RPI_P2 - CONSTRUCTION | RPI_P2 - PHASE | RPI_P2 - ZONES | RPI_P2 - UTILITY NETWORK | Activity Wt% | Weight % | Cost Wt | RPI - PHASE | RPI - CONSTRUCTION | RPI - ZONES | RPI - UTILITY NETWORKS | RPI - TYPE OF WORK |
| --- | --- | --- | --- | --- | --- | --- | --- | --- | --- | --- | --- | --- | --- | --- | --- | --- | --- | --- | --- | --- | --- | --- | --- |
|  | 9 | **Electrical Instalaltion for Irrigation System** |  | 2017-06-22 | 2017-08-24 |  |  |  |  |  |  |  |  |  |  |  |  |  |  |  |  |  |  |
| CON-Z4-UT-IRG-PL-250 |  | Excavation of Trench | 8d | 2017-06-22 | 2017-07-06 | CON-Z4-UT-IRG-PL-130, CON-Z3-UT-IRG-PL-410 | 40.4d | 0d | Common Labor / Helper [26 h]; Operator - Excavator [26 h]; Driver - Dump Truck [26 h]; Operator - JCB [26 h]; Excavator [28 h]; Dump Truck [28 h] | 372.37 | 1.3.5.50 | CONS | CONS | ZONE-4 | IRR |  |  |  |  |  |  |  |  |
| CON-Z4-UT-IRG-PL-260 |  | Sand Bedding | 8d | 2017-07-06 | 2017-07-16 | CON-Z4-UT-IRG-PL-250 | 40.4d | 0d | Common Labor / Helper [104 h]; Operator - Loader [26 h]; Driver - Dump Truck [26 h]; Operator - Bobcat [26 h]; Operator - JCB [26 h]; Loader [28 h]; Dump Truck [28 h]; Bobcat [28 h]; JCB [28 h] | 186.18 | 1.3.5.50 | CONS | CONS | ZONE-4 | IRR |  |  |  |  |  |  |  |  |
| CON-Z4-UT-IRG-PL-270 |  | Instalaltion of direct burial Solid Irrigation Wires | 4d | 2017-07-16 | 2017-07-20 | CON-Z4-UT-IRG-PL-260 | 40.4d | 0d | Electrician [78 h]; LC Crew [52 h] | 744.73 | 1.3.5.50 | CONS | CONS | ZONE-4 | IRR |  |  |  |  |  |  |  |  |
| CON-Z4-UT-IRG-PL-280 |  | Sandfilling,Red Tiles and Warning Tape | 4d | 2017-07-20 | 2017-07-25 | CON-Z4-UT-IRG-PL-270 | 40.4d | 0d | Common Labor / Helper [78 h]; Block Mason [52 h]; Tiling Crew [52 h] | 930.92 | 1.3.5.50 | CONS | CONS | ZONE-4 | IRR |  |  |  |  |  |  |  |  |
| CON-Z4-UT-IRG-PL-290 |  | Backfilling of Trench | 12d | 2017-07-25 | 2017-08-08 | CON-Z4-UT-IRG-PL-280 | 40.4d | 0.6d | Common Labor / Helper [104 h]; Operator - Loader [26 h]; Driver - Dump Truck [26 h]; Operator - Bobcat [26 h]; Operator - Asphalt Compactor / Roller [26 h]; Operator - Roller-Compactor (2~10 Ton) [26 h]; Driver - Water Tanker [26 h]; Operator - JCB [26 h]; Loader [28 h]; Dump Truck [28 h]; Bobcat [28 h]; Roller-Compactor (2~10 Ton) [28 h]; Plate Compactor [28 h]; Vibrators [28 h]; Water Tanker [28 h]; JCB [28 h] | 372.37 | 1.3.5.50 | CONS | CONS | ZONE-4 | IRR |  |  |  |  |  |  |  |  |
| CON-Z4-UT-IRG-PL-300 |  | Installation of Solar Power Irrigation Controller | 6d | 2017-08-09 | 2017-08-16 | CON-Z4-UT-IRG-PL-320 SS, CON-Z4-UT-IRG-PL-240 SS, CON-Z4-UT-IRG-PL-290, CON-Z4-UT-IRG-PL-180 SS | 39.8d | 0d | Electrician [78 h]; LC Crew [52 h] | 744.73 | 1.3.5.50 | CONS | CONS | ZONE-4 | IRR |  |  |  |  |  |  |  |  |
| CON-Z4-UT-IRG-PL-310 |  | Instalaltion of Junction Boxes | 7d | 2017-08-16 | 2017-08-24 | CON-Z4-UT-IRG-PL-300, CON-Z3-UT-IRG-PL-470 SS | 39.8d | 5d | Electrician [78 h]; LC Crew [52 h] | 372.37 | 1.3.5.50 | CONS | CONS | ZONE-4 | IRR |  |  |  |  |  |  |  |  |
|  | 6 | **Storm Water Drainage System** |  | 2016-12-25 | 2017-09-30 |  |  |  |  |  |  |  |  |  |  |  |  |  |  |  |  |  |  |
|  | 11 | **Storm Water Ditch** |  | 2016-12-25 | 2017-03-19 |  |  |  |  |  |  |  |  |  |  |  |  |  |  |  |  |  |  |
|  | 1 | **Storm Water Ditch D-1 (3.5m Width -Type - I)** |  | 2016-12-25 | 2017-02-06 |  |  |  |  |  |  |  |  |  |  |  |  |  |  |  |  |  |  |
| CON-Z4-UTI-SD-0010 |  | Excavation | 4d | 2016-12-25 | 2016-12-29 | CON-Z3-UTI-SD-0010 FS+45d | 81.8d | 0d | JCB [168 h]; Operator - JCB [120 h] | 30,666.36 | 1.3.5.60 | CONS | CONS | ZONE-4 | STORM | 0 | 0 | 0.0099611056 | 6 | RPI - CONS | Z1 | STORM | CIVIL |
| CON-Z4-UTI-SD-0020 |  | Backfilling / Compaction, Bed Preparation, Polyethylene Sheet Vapor Barrier | 6.4d | 2016-12-29 | 2017-01-05 | CON-Z4-UTI-SD-0010, CON-Z4-UTI-SD-0010 SS+4d | 208.2d | 0d | Common Labor / Helper [104 h]; Painter [52 h]; Water Proofing Crew [52 h]; Operator - Loader [64 h]; Driver - Dump Truck [64 h]; Operator - Bobcat [64 h]; Operator - Roller-Compactor (2~10 Ton) [64 h]; Driver - Water Tanker [64 h]; Operator - JCB [64 h]; Loader [89.6 h]; Dump Truck [89.6 h]; Bobcat [89.6 h]; Roller-Compactor (2~10 Ton) [89.6 h]; Plate Compactor [89.6 h] | 51,110.6 | 1.3.5.60 | CONS | CONS | ZONE-4 | STORM | 0 | 0 | 0.0199222112 | 6 | RPI - CONS | Z1 | STORM | CIVIL |
| CON-Z4-UTI-SD-0030 |  | Welded Wire Mesh and Concrete Works | 12d | 2016-12-31 | 2017-01-14 | CON-Z4-UTI-SD-0020 SS+1.6d | 208.2d | 0d | Finishing Work Crew [52 h]; Driver - Conc. Transit Mixers [26 h]; Operator - Concrete Pump [26 h]; Concrete Transit Mixers [28 h]; Concrete Pump [28 h]; Shuttering Carpenter [78 h]; Concrete Mason [78 h]; Common Labor / Helper [104 h] | 81,776.96 | 1.3.5.60 | CONS | CONS | ZONE-4 | STORM | 0 | 0 | 0.0597666337 | 6 | RPI - CONS | Z1 | STORM | CIVIL |
| CON-Z4-UTI-SD-0040 |  | Bitumen Coating & Backfilling | 16d | 2017-01-18 | 2017-02-06 | CON-Z4-UTI-SD-0030 FS+4d | 208.2d | 5d | Common Labor / Helper [78 h]; Loader [28 h]; Dump Truck [28 h]; Bobcat [28 h]; Roller-Compactor (2~10 Ton) [28 h]; Roller-Compactor (25 Ton) [28 h]; Water Tanker [28 h] | 40,888.48 | 1.3.5.60 | CONS | CONS | ZONE-4 | STORM | 0 | 0 | 0.0099611056 | 6 | RPI - CONS | Z1 | STORM | CIVIL |
|  | 2 | **Storm Water Ditch D-2 (3.5m Width -Type - I)** |  | 2016-12-29 | 2017-03-19 |  |  |  |  |  |  |  |  |  |  |  |  |  |  |  |  |  |  |
| CON-Z4-UTI-SD-0050 |  | Excavation | 8d | 2016-12-29 | 2017-01-08 | CON-Z4-UTI-SD-0010 | 81.8d | 0d |  | 30,666.36 | 1.3.5.60 | CONS | CONS | ZONE-4 | STORM | 0 | 0 | 0.0099611056 | 6 | RPI - CONS | Z1 | STORM | CIVIL |
| CON-Z4-UTI-SD-0060 |  | Backfilling / Compaction, Bed Preparation, Polyethylene Sheet Vapor Barrier | 10d | 2017-01-08 | 2017-01-19 | CON-Z4-UTI-SD-0050 SS+4d, CON-Z4-UTI-SD-0050 | 203.2d | 0d | Common Labor / Helper [78 h]; Loader [28 h]; Dump Truck [28 h]; Bobcat [28 h]; Roller-Compactor (2~10 Ton) [28 h]; Plate Compactor [28 h]; Vibrators [28 h]; Water Tanker [28 h]; JCB [28 h] | 51,110.6 | 1.3.5.60 | CONS | CONS | ZONE-4 | STORM | 0 | 0 | 0.0199222112 | 6 | RPI - CONS | Z1 | STORM | CIVIL |
| CON-Z4-UTI-SD-0070 |  | Welded Wire Mesh and Concrete Works | 25d | 2017-01-09 | 2017-02-07 | CON-Z4-UTI-SD-0060 SS+1.6d | 203.2d | 0d | Shuttering Carpenter [78 h]; Concrete Mason [78 h]; Common Labor / Helper [104 h]; Finishing Work Crew [52 h]; Driver - Conc. Transit Mixers [26 h]; Operator - Concrete Pump [26 h]; Concrete Transit Mixers [28 h]; Concrete Pump [28 h] | 81,776.96 | 1.3.5.60 | CONS | CONS | ZONE-4 | STORM | 0 | 0 | 0.0597666337 | 6 | RPI - CONS | Z1 | STORM | CIVIL |
| CON-Z4-UTI-SD-0080 |  | Bitumen Coating & Backfilling | 30d | 2017-02-12 | 2017-03-19 | CON-Z4-UTI-SD-0040, CON-Z4-UTI-SD-0070 FS+4d | 203.2d | 121.4d | Common Labor / Helper [78 h]; Loader [28 h]; Dump Truck [28 h]; Bobcat [28 h]; Roller-Compactor (2~10 Ton) [28 h]; Roller-Compactor (25 Ton) [28 h]; Water Tanker [28 h] | 40,888.48 | 1.3.5.60 | CONS | CONS | ZONE-4 | STORM | 0 | 0 | 0.0099611056 | 6 | RPI - CONS | Z1 | STORM | CIVIL |
|  | 1 | **Drainage Ponds** |  | 2017-05-28 | 2017-09-30 |  |  |  |  |  |  |  |  |  |  |  |  |  |  |  |  |  |  |
|  | 1 | **Drainage Pond - 3** |  | 2017-05-28 | 2017-07-24 |  |  |  |  |  |  |  |  |  |  |  |  |  |  |  |  |  |  |
| CON-Z4-POND-03-0010 |  | Excavation | 12d | 2017-05-28 | 2017-06-11 | CON-Z4-UTI-SD-0050 FS+120d | 81.8d | 0d | Operator - Excavator [78 h]; Excavator [84 h] | 30,666.36 | 1.3.5.60 | CONS | CONS | ZONE-4 | STORM |  |  |  |  |  |  |  |  |
| CON-Z4-POND-03-0020 |  | Compacted Marl Fill 500mm thk for Pond | 32d | 2017-06-11 | 2017-07-23 | CON-Z4-POND-03-0010 | 81.8d | 0d | Common Labor / Helper [130 h]; Operator - Loader [52 h]; Driver - Dump Truck [104 h]; Operator - Bobcat [26 h]; Operator - Roller (25 Ton) [26 h]; Driver - Water Tanker [26 h]; Driver - Fuel Tanker [26 h]; Loader [56 h]; Dump Truck [112 h]; Bobcat [28 h]; Roller-Compactor (25 Ton) [56 h]; Water Tanker [28 h]; Dewatering Pumps [28 h] | 107,332.26 | 1.3.5.60 | CONS | CONS | ZONE-4 | STORM |  |  |  |  |  |  |  |  |
| CON-Z4-POND-03-0030 |  | Marl Caping 200mm thk | 16d | 2017-06-15 | 2017-07-09 | CON-Z4-POND-03-0020 SS+4d | 81.8d | 0d | Common Labor / Helper [130 h] | 61,332.72 | 1.3.5.60 | CONS | CONS | ZONE-4 | STORM |  |  |  |  |  |  |  |  |
| CON-Z4-POND-03-0040 |  | Compacted Marl Fill 500mm thk for Walkway | 12d | 2017-07-09 | 2017-07-23 | CON-Z4-UTI-SD-0080 SS, CON-Z4-POND-03-0030 | 81.8d | 0d | Common Labor / Helper [130 h]; Operator - Roller (25 Ton) [26 h]; Driver - Water Tanker [26 h]; Roller-Compactor (25 Ton) [28 h]; Water Tanker [28 h] | 30,666.36 | 1.3.5.60 | CONS | CONS | ZONE-4 | STORM |  |  |  |  |  |  |  |  |
| CON-Z4-POND-03-0050 |  | Instalaltion of Chain Link Fence and Gates | 8d | 2017-07-15 | 2017-07-24 | CON-Z4-POND-03-0040 SS+5d | 81.8d | 45d | Shuttering Carpenter [52 h]; Concrete Mason [52 h]; Welder [26 h]; Common Labor / Helper [104 h]; Operator - Forklift [26 h] | 76,665.9 | 1.3.5.60 | CONS | CONS | ZONE-4 | STORM |  |  |  |  |  |  |  |  |

Notes:
- CON-Z4-UT-IRG-PL-250: Expenses: (New Expense Item) 372.37
- CON-Z4-UT-IRG-PL-260: Expenses: (New Expense Item) 186.18
- CON-Z4-UT-IRG-PL-270: Expenses: (New Expense Item) 744.73
- CON-Z4-UT-IRG-PL-280: Expenses: (New Expense Item) 930.92
- CON-Z4-UT-IRG-PL-290: Expenses: (New Expense Item) 372.37
- CON-Z4-UT-IRG-PL-300: Expenses: (New Expense Item) 744.73
- CON-Z4-UT-IRG-PL-310: Expenses: (New Expense Item) 372.37
- CON-Z4-UTI-SD-0010: Expenses: (New Expense Item) 30666.4
- CON-Z4-UTI-SD-0020: Expenses: (New Expense Item) 51110.6
- CON-Z4-UTI-SD-0030: Expenses: (New Expense Item) 81777
- CON-Z4-UTI-SD-0040: Expenses: (New Expense Item) 40888.5
- CON-Z4-UTI-SD-0050: Expenses: (New Expense Item) 30666.4
- CON-Z4-UTI-SD-0060: Expenses: (New Expense Item) 51110.6
- CON-Z4-UTI-SD-0070: Expenses: (New Expense Item) 81777
- CON-Z4-UTI-SD-0080: Expenses: (New Expense Item) 40888.5
- CON-Z4-POND-03-0010: Expenses: (New Expense Item) 30666.4
- CON-Z4-POND-03-0020: Expenses: (New Expense Item) 107332
- CON-Z4-POND-03-0030: Expenses: (New Expense Item) 61332.7
- CON-Z4-POND-03-0040: Expenses: (New Expense Item) 30666.4
- CON-Z4-POND-03-0050: Expenses: (New Expense Item) 76665.9

| ID | WBS | Activity | Duration | Start | Finish | Predecessors | Total float | Free float | Resources | Cost | RPI_P2 - BOQ ITEMS | RPI_P2 - CONSTRUCTION | RPI_P2 - PHASE | RPI_P2 - ZONES | RPI_P2 - UTILITY NETWORK | RPI_P2 - AREAS |
| --- | --- | --- | --- | --- | --- | --- | --- | --- | --- | --- | --- | --- | --- | --- | --- | --- |
|  | 2 | **Drainage Pond - 5** |  | 2017-06-11 | 2017-09-30 |  |  |  |  |  |  |  |  |  |  |  |
| CON-Z4-POND-05-0010 |  | Excavation | 12d | 2017-06-11 | 2017-06-25 | CON-Z4-POND-03-0010 | 81.8d | 0d | Operator - Excavator [78 h]; Excavator [168 h] | 30,666.36 | 1.3.5.60 | CONS | CONS | ZONE-4 | STORM |  |
| CON-Z4-POND-05-0020 |  | Compacted Marl Fill 500mm thk for Pond | 32d | 2017-06-25 | 2017-08-06 | CON-Z4-POND-05-0010 | 81.8d | 0d | Common Labor / Helper [130 h]; Operator - Loader [52 h]; Driver - Dump Truck [104 h]; Operator - Bobcat [26 h]; Operator - Roller (25 Ton) [26 h]; Driver - Water Tanker [26 h]; Driver - Fuel Tanker [26 h] | 107,332.26 | 1.3.5.60 | CONS | CONS | ZONE-4 | STORM |  |
| CON-Z4-POND-05-0030 |  | Marl Caping 200mm thk | 16d | 2017-07-04 | 2017-07-23 | CON-Z4-POND-05-0020 SS+4d | 81.8d | 0d | Common Labor / Helper [130 h] | 61,332.72 | 1.3.5.60 | CONS | CONS | ZONE-4 | STORM |  |
| CON-Z4-POND-05-0040 |  | Compacted Marl Fill 500mm thk for Walkway | 12d | 2017-07-10 | 2017-07-24 | CON-Z4-POND-05-0030 SS+5d | 81.8d | 45d | Common Labor / Helper [130 h]; Operator - Roller (25 Ton) [26 h]; Driver - Water Tanker [26 h] | 30,666.36 | 1.3.5.60 | CONS | CONS | ZONE-4 | STORM |  |
| CON-Z4-POND-05-0050 |  | Instalaltion of Chain Link Fence and Gates | 8d | 2017-09-19 | 2017-09-30 | CON-Z3-POND-06-0050 SS, CON-Z4-POND-03-0050, CON-Z4-POND-05-0040 | 36.8d | 2d | Shuttering Carpenter [52 h]; Concrete Mason [52 h]; Welder [240 h]; Common Labor / Helper [1200 h]; Operator - Forklift [26 h] | 76,665.9 | 1.3.5.60 | CONS | CONS | ZONE-4 | STORM |  |
|  | 9 | **Road Networks** |  | 2017-04-30 | 2017-07-25 |  |  |  |  |  |  |  |  |  |  |  |
|  | 3 | **New Roads** |  | 2017-04-30 | 2017-05-11 |  |  |  |  |  |  |  |  |  |  |  |
|  | 2 | **Patrol Road (4m Wide)** |  | 2017-04-30 | 2017-05-11 |  |  |  |  |  |  |  |  |  |  |  |
| CON-Z4-UTI-RD-PT-010 |  | Maintaining of Patrol Road | 10d | 2017-04-30 | 2017-05-11 | CON-Z3-UTI-RD-R4-010 FS+22d | 65.8d | 0d | Common Labor / Helper [78 h]; Operator - Loader [26 h]; Operator - Grader [26 h]; Loader [28 h]; Grader [28 h] | 137,665.8 |  | CONS | CONS | ZONE-4 | ROAD | PATROL RD |
|  | 1 | **Existing Roads (Remaining Road Works including Road Crossings)** |  | 2017-05-11 | 2017-07-25 |  |  |  |  |  |  |  |  |  |  |  |
|  | 2 | **Road 3** |  | 2017-05-11 | 2017-06-15 |  |  |  |  |  |  |  |  |  |  |  |
| CON-Z4-UTI-RD-R3-010 |  | Remaining Road Works and Reisntatement of Existing Road Works of Road 3 | 30d | 2017-05-11 | 2017-06-15 | CON-Z4-UTI-RD-PT-010 | 65.8d | 0d | Common Labor / Helper [104 h]; Road Works Crew [52 h]; Operator - Excavator [26 h]; Operator - Loader [26 h]; Driver - Dump Truck [26 h]; Operator - Grader [26 h]; Operator - Bobcat [26 h]; Operator - Asphalt Paver [26 h]; Operator - Asphalt Compactor / Roller [26 h]; Operator - Roller (25 Ton) [26 h]; Driver - Water Tanker [26 h]; Operator - JCB [26 h]; Excavator [28 h]; Loader [28 h]; Dump Truck [28 h]; Grader [28 h]; Bobcat [28 h]; Asphalt Paver [28 h]; Asphalt Compactor / Roller [28 h]; JCB [28 h] | 53,420.7 |  | CONS | CONS | ZONE-4 | ROAD | ROAD-3 |
|  | 3 | **Road E** |  | 2017-06-15 | 2017-07-25 |  |  |  |  |  |  |  |  |  |  |  |
| CON-Z4-UTI-RD-RE-010 |  | Remaining Road Works and Reisntatement of Existing Road Works of Road 3 | 30d | 2017-06-15 | 2017-07-25 | CON-Z4-UTI-RD-R3-010 | 65.8d | 8.6d | Common Labor / Helper [104 h]; Road Works Crew [52 h]; Operator - Excavator [26 h]; Operator - Loader [26 h]; Driver - Dump Truck [26 h]; Operator - Grader [26 h]; Operator - Bobcat [26 h]; Operator - Asphalt Paver [26 h]; Operator - Asphalt Compactor / Roller [26 h]; Operator - Roller (25 Ton) [26 h]; Driver - Water Tanker [26 h]; Operator - JCB [26 h]; Excavator [28 h]; Loader [28 h]; Dump Truck [28 h]; Grader [28 h]; Bobcat [28 h]; Asphalt Paver [28 h]; Asphalt Compactor / Roller [28 h]; JCB [28 h] | 53,420.7 |  | CONS | CONS | ZONE-4 | ROAD | ROAD-E |
|  | 7 | **Electrical Works** |  | 2017-01-01 | 2017-08-29 |  |  |  |  |  |  |  |  |  |  |  |
|  | 1 | **MV Cables,Transformers,RMU'S and Unit Sub Stations (Loop 12)** |  | 2017-01-01 | 2017-08-29 |  |  |  |  |  |  |  |  |  |  |  |
| CONC-Z4-UTIL-ELE-010 |  | Excavation and Cleaning for MV cable trench | 12d | 2017-01-01 | 2017-01-15 | CONC-Z3-UTIL-ELE-660 SS | 9.8d | 0d | Common Labor / Helper [52 h]; Operator - JCB [26 h]; JCB [28 h] | 90,679.13 | 1.3.5.70 | CONS | CONS | ZONE-4 | POWER |  |
| CONC-Z4-UTIL-ELE-020 |  | Sand Bedding of MV Cable Trench | 8d | 2017-01-15 | 2017-01-24 | CONC-Z4-UTIL-ELE-010 | 9.8d | 0d | Common Labor / Helper [104 h]; Operator - Loader [26 h]; Driver - Dump Truck [26 h]; Operator - Bobcat [26 h]; Operator - JCB [26 h]; Loader [28 h]; Dump Truck [28 h]; Bobcat [28 h]; JCB [28 h] | 45,339.56 | 1.3.5.70 | CONS | CONS | ZONE-4 | POWER |  |
| CONC-Z4-UTIL-ELE-030 |  | MV Cable Pulling | 16d | 2017-01-24 | 2017-02-12 | CONC-Z4-UTIL-ELE-020 | 9.8d | 0d | Electrician [78 h]; Common Labor / Helper [104 h]; Operator - Forklift [26 h]; Forklift [28 h] | 136,018.69 | 1.3.5.70 | CONS | CONS | ZONE-4 | POWER |  |
| CONC-Z4-UTIL-ELE-040 |  | Splicing and Termination of MV Cables | 8d | 2017-02-12 | 2017-02-21 | CONC-Z4-UTIL-ELE-030 | 9.8d | 0d | Electrician [78 h]; Specialist Works Crew [26 h] | 45,339.56 | 1.3.5.70 | CONS | CONS | ZONE-4 | POWER |  |
| CONC-Z4-UTIL-ELE-050 |  | Soft Sand Filling | 8d | 2017-02-21 | 2017-03-02 | CONC-Z4-UTIL-ELE-040 | 9.8d | 0d | Common Labor / Helper [104 h]; Driver - Water Tanker [26 h]; Operator - JCB [26 h]; Water Tanker [28 h]; JCB [28 h] | 18,135.83 | 1.3.5.70 | CONS | CONS | ZONE-4 | POWER |  |
| CONC-Z4-UTIL-ELE-060 |  | Installation of Red Tiles and Warning Tape | 16d | 2017-03-02 | 2017-03-21 | CONC-Z4-UTIL-ELE-050 | 9.8d | 0d | Common Labor / Helper [78 h]; Block Mason [52 h]; Tiling Crew [52 h] | 27,203.74 | 1.3.5.70 | CONS | CONS | ZONE-4 | POWER |  |
| CONC-Z4-UTIL-ELE-070 |  | Final Backfilling | 24d | 2017-03-21 | 2017-04-18 | CONC-Z4-UTIL-ELE-060 | 9.8d | 0d | Common Labor / Helper [104 h]; Operator - Loader [26 h]; Driver - Dump Truck [26 h]; Operator - Bobcat [26 h]; Operator - Asphalt Compactor / Roller [26 h]; Operator - Roller-Compactor (2~10 Ton) [26 h]; Driver - Water Tanker [26 h]; Operator - JCB [26 h]; Loader [28 h]; Dump Truck [28 h]; Bobcat [28 h]; Roller-Compactor (2~10 Ton) [28 h]; Roller-Compactor (25 Ton) [28 h]; Water Tanker [28 h] | 90,679.13 | 1.3.5.70 | CONS | CONS | ZONE-4 | POWER |  |
| CONC-Z4-UTIL-ELE-080 |  | Testing and Precommissioning of MV Cables | 20d | 2017-05-06 | 2017-05-29 | CONC-Z4-UTIL-ELE-070 FS+15d | 9.8d | 0d | Plumber [52 h]; Common Labor / Helper [52 h]; RTR Pipe Crew [52 h]; Driver - Water Tanker [26 h] | 90,679.13 | 1.3.5.70 | CONS | CONS | ZONE-4 | POWER |  |
| CONC-Z4-UTIL-ELE-140 |  | Installation of Cable Markers | 32d | 2017-05-06 | 2017-06-12 | CONC-Z4-UTIL-ELE-070 FS+15d | 98.8d | 64.8d | Common Labor / Helper [78 h] | 45,339.56 | 1.3.5.70 | CONS | CONS | ZONE-4 | POWER |  |
| CONC-Z4-UTIL-ELE-090 |  | Installation of Concrete Foundation for remaining RMU'S and Tranformers | 16d | 2017-05-29 | 2017-06-17 | PR-Z4-EW-EL-180-0080, CONC-Z4-UTIL-ELE-080 | 9.8d | 0d | Steel Fixer [52 h]; Shuttering Carpenter [78 h]; Concrete Mason [78 h]; Common Labor / Helper [52 h]; Driver - Conc. Transit Mixers [26 h]; Operator - Concrete Pump [26 h]; Concrete Transit Mixers [28 h]; Concrete Pump [28 h] | 45,339.56 | 1.3.5.70 | CONS | CONS | ZONE-4 | POWER |  |
| CONC-Z4-UTIL-ELE-100 |  | Installation of RMU'S,Transformers and Unit Substations | 16d | 2017-06-17 | 2017-07-10 | CONC-Z4-UTIL-ELE-090 | 9.8d | 0d | Electrician [78 h]; Mechanical Technician [26 h]; HVAC Crew [26 h] | 45,339.56 | 1.3.5.70 | CONS | CONS | ZONE-4 | POWER |  |
| CONC-Z4-UTIL-ELE-110 |  | Testing and Precommissioning of RMU'S Transformers and Unit Substations | 16d | 2017-07-10 | 2017-07-29 | CONC-Z4-UTIL-ELE-100, CONC-Z4-UTIL-ELE-080 | 9.8d | 0d | Electrician [78 h]; Common Labor / Helper [26 h] | 45,339.56 | 1.3.5.70 | CONS | CONS | ZONE-4 | POWER |  |
| CONC-Z4-UTIL-ELE-120 |  | Energizing of MV Cables | 24d | 2017-07-13 | 2017-08-10 | CONC-Z4-UTIL-ELE-080, CONC-Z4-UTIL-ELE-110 SS+3d | 19.8d | 17d | Electrician [104 h] | 90,679.13 | 1.3.5.70 | CONS | CONS | ZONE-4 | POWER |  |
| CONC-Z4-UTIL-ELE-130 |  | Energizing of RMU'S Transformers and Unit Substations | 20d | 2017-08-06 | 2017-08-29 | CONC-Z4-UTIL-ELE-120 SS+3d, CONC-Z4-UTIL-ELE-110, CONC-Z3-UTIL-ELE-780 SS | 2.8d | 0d | Electrician [104 h] | 90,679.13 | 1.3.5.70 | CONS | CONS | ZONE-4 | POWER |  |

Notes:
- CON-Z4-POND-05-0010: Expenses: (New Expense Item) 30666.4
- CON-Z4-POND-05-0020: Expenses: (New Expense Item) 107332
- CON-Z4-POND-05-0030: Expenses: (New Expense Item) 61332.7
- CON-Z4-POND-05-0040: Expenses: (New Expense Item) 30666.4
- CON-Z4-POND-05-0050: Expenses: (New Expense Item) 76665.9
- CON-Z4-UTI-RD-PT-010: Expenses: (New Expense Item) 137666
- CON-Z4-UTI-RD-R3-010: Expenses: (New Expense Item) 53420.7
- CON-Z4-UTI-RD-RE-010: Expenses: (New Expense Item) 53420.7
- CONC-Z4-UTIL-ELE-010: Expenses: (New Expense Item) 90679.1
- CONC-Z4-UTIL-ELE-020: Expenses: (New Expense Item) 45339.6
- CONC-Z4-UTIL-ELE-030: Expenses: (New Expense Item) 136019
- CONC-Z4-UTIL-ELE-040: Expenses: (New Expense Item) 45339.6
- CONC-Z4-UTIL-ELE-050: Expenses: (New Expense Item) 18135.8
- CONC-Z4-UTIL-ELE-060: Expenses: (New Expense Item) 27203.7
- CONC-Z4-UTIL-ELE-070: Expenses: (New Expense Item) 90679.1
- CONC-Z4-UTIL-ELE-080: Expenses: (New Expense Item) 90679.1
- CONC-Z4-UTIL-ELE-140: Expenses: (New Expense Item) 45339.6
- CONC-Z4-UTIL-ELE-090: Expenses: (New Expense Item) 45339.6
- CONC-Z4-UTIL-ELE-100: Expenses: (New Expense Item) 45339.6
- CONC-Z4-UTIL-ELE-110: Expenses: (New Expense Item) 45339.6
- CONC-Z4-UTIL-ELE-120: Expenses: (New Expense Item) 90679.1
- CONC-Z4-UTIL-ELE-130: Expenses: (New Expense Item) 90679.1

| ID | WBS | Activity | Duration | Start | Finish | Predecessors | Total float | Free float | Resources | Cost | RPI_P2 - BOQ ITEMS | RPI_P2 - CONSTRUCTION | RPI_P2 - PHASE | RPI_P2 - ZONES | RPI_P2 - AREAS | RPI_P2 - UTILITY NETWORK | Wajid |
| --- | --- | --- | --- | --- | --- | --- | --- | --- | --- | --- | --- | --- | --- | --- | --- | --- | --- |
|  | 2 | **Street Lighting Works (LV)** |  | 2017-08-01 | 2017-08-29 |  |  |  |  |  |  |  |  |  |  |  |  |
|  | 1 | **Road 3** |  | 2017-08-01 | 2017-08-24 |  |  |  |  |  |  |  |  |  |  |  |  |
| CONC-Z4-UTIL-SL-010 |  | Completion of Remaining Street Lighting Works and Reinstatement of Existing Works | 20d | 2017-08-01 | 2017-08-24 | CONC-Z4-UTIL-ELE-010 FS+166d | 39.8d | 0d | Electrician [52 h]; Common Labor / Helper [78 h]; LC Crew [52 h] | 194,312.42 | 1.3.5.70 | CONS | CONS | ZONE-4 | ROAD-3 | POWER |  |
|  | 2 | **Road E** |  | 2017-08-06 | 2017-08-29 |  |  |  |  |  |  |  |  |  |  |  |  |
| CONC-Z4-UTIL-SL-10 |  | Completion of Remaining Street Lighting Works and Reinstatement of Existing Works | 20d | 2017-08-06 | 2017-08-29 | CONC-Z4-UTIL-SL-010 SS+4d | 127.8d |  | Electrician [52 h]; Common Labor / Helper [78 h]; LC Crew [52 h] | 194,312.42 | 1.3.5.70 | CONS | CONS | ZONE-4 | ROAD-E | POWER |  |
|  | 8 | **Communication & Security Systems** |  | 2017-05-15 | 2017-11-01 |  |  |  |  |  |  |  |  |  |  |  |  |
|  | 1 | **FOC and Copper Cable System** |  | 2017-05-15 | 2017-09-20 |  |  |  |  |  |  |  |  |  |  |  |  |
| CON-Z4-UTIL-COM-0010 |  | Installation of Sub-Ducts for FOC | 30d | 2017-05-15 | 2017-06-19 | CON-Z3-UTIL-COM-0010 SS+12d, PR-Z4-CO-LV-190-0090 FS+110d | 0.6d | 0d |  | 59,663.42 | 1.3.5.80 | CONS | CONS | ZONE-4 |  | COMM | OK |
| CON-Z4-UTIL-COM-0020 |  | Installation of FOC and Copper Cables in Zone 4 | 26d | 2017-06-19 | 2017-07-24 | PR-Z4-CO-LV-186-0090, PR-Z4-CO-LV-185-0090, CON-Z4-UTIL-COM-0010, PR-Z4-CO-LV-181-0090 | 0.6d | 0d | Electrician [130 h] | 238,653.7 | 1.3.5.80 | CONS | CONS | ZONE-4 |  | COMM | OK |
| CON-Z4-UTIL-COM-0030 |  | Splicing and Termination of FOC and Copper Cables in Zone 4 | 26d | 2017-07-17 | 2017-08-16 | CON-Z4-UTIL-COM-0020 SS+20d, PR-Z4-CO-LV-186-0090 | 17.6d | 0d |  | 178,990.27 | 1.3.5.80 | CONS | CONS | ZONE-4 |  | COMM | OK |
| CON-Z4-UTIL-COM-0040 |  | Testing and Precommissioning of FOC and Copper Cables in Zone 4 | 26d | 2017-08-16 | 2017-09-20 | CON-Z4-UTIL-COM-0030 | 17.6d | 17d | Electrician [780 h]; LC Crew [260 h] | 119,326.85 | 1.3.5.80 | CONS | CONS | ZONE-4 |  | COMM | OK |
|  | 2 | **Code Blue System** |  | 2017-06-19 | 2017-10-03 |  |  |  |  |  |  |  |  |  |  |  |  |
|  | 1 | **Code Blue Cable Works** |  | 2017-06-19 | 2017-09-18 |  |  |  |  |  |  |  |  |  |  |  |  |
| CON-Z4-UTIL-COM-0050 |  | Excavation for Code Blue LV Cable Trench | 12d | 2017-06-19 | 2017-07-08 | CON-Z4-UTIL-COM-0020 SS | 0.6d | 0d | JCB [168 h]; Operator - JCB [120 h] | 11,262.42 | 1.3.5.80 | CONS | CONS | ZONE-4 |  | COMM | OK |
| CON-Z4-UTIL-COM-0060 |  | Compaction and Sand bedding for Code Blue LV Cable Trench | 8d | 2017-07-08 | 2017-07-17 | CON-Z4-UTIL-COM-0050 | 7.6d | 0d |  | 11,262.42 | 1.3.5.80 | CONS | CONS | ZONE-4 |  | COMM | OK |
| CON-Z4-UTIL-COM-0070 |  | Installation of Code Blue LV Cables | 21d | 2017-07-17 | 2017-08-10 | CON-Z4-UTIL-COM-0060 | 7.6d | 0d |  | 33,787.26 | 1.3.5.80 | CONS | CONS | ZONE-4 |  | COMM | OK |
| CON-Z4-UTIL-COM-0080 |  | Sand Backfillling for Code Blue LV Cable Trench | 8d | 2017-08-10 | 2017-08-20 | CON-Z4-UTIL-COM-0070 | 7.6d | 0d |  | 11,262.42 | 1.3.5.80 | CONS | CONS | ZONE-4 |  | COMM | OK |
| CON-Z4-UTIL-COM-0090 |  | Instalation of Red Tiles and Warning Tape | 9d | 2017-08-20 | 2017-08-30 | CON-Z4-UTIL-COM-0080 | 7.6d | 0d |  | 22,524.84 | 1.3.5.80 | CONS | CONS | ZONE-4 |  | COMM | OK |
| CON-Z4-UTIL-COM-0100 |  | Final Backfilling | 12d | 2017-08-30 | 2017-09-18 | CON-Z4-UTIL-COM-0090 | 7.6d | 0d |  | 22,524.84 | 1.3.5.80 | CONS | CONS | ZONE-4 |  | COMM | OK |
|  | 2 | **Code Blue Pedestals (3 No.)** |  | 2017-06-21 | 2017-10-03 |  |  |  |  |  |  |  |  |  |  |  |  |
| CON-Z4-UTIL-COM-0110 |  | Excavation for foundations of Code Blue Pedestals | 4d | 2017-06-21 | 2017-07-01 | CON-Z4-UTIL-COM-0050 SS+2d | 0.6d | 0d | JCB [56 h]; Operator - JCB [40 h] | 7,240.13 | 1.3.5.80 | CONS | CONS | ZONE-4 |  | COMM | OK |
| CON-Z4-UTIL-COM-0120 |  | Compaction and Lean Concrete | 4d | 2017-07-01 | 2017-07-05 | CON-Z4-UTIL-COM-0110 | 47.6d | 0d | Concrete Mason [80 h] | 4,826.75 | 1.3.5.80 | CONS | CONS | ZONE-4 |  | COMM | OK |
| CON-Z4-UTIL-COM-0130 |  | Installation of Code Blue Concrete Foundations including Anchor Bolts | 8d | 2017-07-05 | 2017-07-15 | CON-Z4-UTIL-COM-0120 | 47.6d | 0d |  | 12,066.88 | 1.3.5.80 | CONS | CONS | ZONE-4 |  | COMM | OK |
| CON-Z4-UTIL-COM-0140 |  | Installation of Code Blue Pedestals | 6d | 2017-07-15 | 2017-07-22 | CON-Z4-UTIL-COM-0130 | 47.6d | 0d |  | 9,653.5 | 1.3.5.80 | CONS | CONS | ZONE-4 |  | COMM | OK |
| CON-Z4-UTIL-COM-0150 |  | Termination of Cables | 6d | 2017-07-22 | 2017-07-29 | CON-Z4-UTIL-COM-0140 | 47.6d | 40d |  | 4,826.75 | 1.3.5.80 | CONS | CONS | ZONE-4 |  | COMM | OK |
| CON-Z4-UTIL-COM-0160 |  | Testing and Precommissioning of Code Blue System | 12d | 2017-09-18 | 2017-10-03 | CON-Z4-UTIL-COM-0100, CON-Z4-UTIL-COM-0150 | 7.6d | 7d |  | 9,653.5 | 1.3.5.80 | CONS | CONS | ZONE-4 |  | COMM | OK |

Notes:
- CONC-Z4-UTIL-SL-010: Expenses: (New Expense Item) 194312
- CONC-Z4-UTIL-SL-10: Expenses: (New Expense Item) 194312
- CON-Z4-UTIL-COM-0010: Expenses: (New Expense Item) 59663.4
- CON-Z4-UTIL-COM-0020: Expenses: (New Expense Item) 238654
- CON-Z4-UTIL-COM-0030: Expenses: (New Expense Item) 178990
- CON-Z4-UTIL-COM-0040: Expenses: (New Expense Item) 119327
- CON-Z4-UTIL-COM-0050: Expenses: (New Expense Item) 11262.4
- CON-Z4-UTIL-COM-0060: Expenses: (New Expense Item) 11262.4
- CON-Z4-UTIL-COM-0070: Expenses: (New Expense Item) 33787.3
- CON-Z4-UTIL-COM-0080: Expenses: (New Expense Item) 11262.4
- CON-Z4-UTIL-COM-0090: Expenses: (New Expense Item) 22524.8
- CON-Z4-UTIL-COM-0100: Expenses: (New Expense Item) 22524.8
- CON-Z4-UTIL-COM-0110: Expenses: (New Expense Item) 7240.13
- CON-Z4-UTIL-COM-0120: Expenses: (New Expense Item) 4826.75
- CON-Z4-UTIL-COM-0130: Expenses: (New Expense Item) 12066.9
- CON-Z4-UTIL-COM-0140: Expenses: (New Expense Item) 9653.5
- CON-Z4-UTIL-COM-0150: Expenses: (New Expense Item) 4826.75
- CON-Z4-UTIL-COM-0160: Expenses: (New Expense Item) 9653.5

| ID | WBS | Activity | Duration | Start | Finish | Predecessors | Total float | Free float | Resources | Cost | Wajid | RPI_P2 - BOQ ITEMS | RPI_P2 - CONSTRUCTION | RPI_P2 - PHASE | RPI_P2 - ZONES | RPI_P2 - UTILITY NETWORK |
| --- | --- | --- | --- | --- | --- | --- | --- | --- | --- | --- | --- | --- | --- | --- | --- | --- |
|  | 3 | **CCTV Works** |  | 2017-06-21 | 2017-11-01 |  |  |  |  |  |  |  |  |  |  |  |
|  | 1 | **External Cabling For CCTV System** |  | 2017-06-21 | 2017-10-11 |  |  |  |  |  |  |  |  |  |  |  |
|  | 1 | **LV Power Cables (Direct Burried) For Camera** |  | 2017-06-21 | 2017-10-11 |  |  |  |  |  |  |  |  |  |  |  |
| CON-Z4-UTIL-COM-0170 |  | Excavation for LV Cable Trench for Camera | 9d | 2017-06-21 | 2017-07-06 | CON-Z4-UTIL-COM-0110 SS | 0.6d | 0d |  | 6,924.76 | OK | 1.3.5.80 | CONS | CONS | ZONE-4 | COMM |
| CON-Z4-UTIL-COM-0180 |  | Compaction and Sand bedding for LV Cable Trench for Camera | 12d | 2017-07-06 | 2017-07-20 | CON-Z4-UTIL-COM-0170 | 0.6d | 0d |  | 6,924.76 | OK | 1.3.5.80 | CONS | CONS | ZONE-4 | COMM |
| CON-Z4-UTIL-COM-0190 |  | Instalaltion of LV Cables for Camera | 12d | 2017-07-20 | 2017-08-03 | CON-Z4-UTIL-COM-0180 | 0.6d | 0d |  | 20,774.29 | OK | 1.3.5.80 | CONS | CONS | ZONE-4 | COMM |
| CON-Z4-UTIL-COM-0200 |  | Sand Backfilling for Code Blue LV Cable Trench | 12d | 2017-08-03 | 2017-08-17 | CON-Z4-UTIL-COM-0190 | 0.6d | 0d |  | 3,462.38 | OK | 1.3.5.80 | CONS | CONS | ZONE-4 | COMM |
| CON-Z4-UTIL-COM-0210 |  | Installation of Red Tiles and Warning Tape | 12d | 2017-08-17 | 2017-09-05 | CON-Z4-UTIL-COM-0200 | 0.6d | 0d |  | 13,849.52 | OK | 1.3.5.80 | CONS | CONS | ZONE-4 | COMM |
| CON-Z4-UTIL-COM-0220 |  | Final Backfilling | 18d | 2017-09-05 | 2017-09-27 | CON-Z4-UTIL-COM-0210 | 0.6d | 0d | JCB [540 h]; Operator - JCB [540 h]; Vibrators [720 h]; Roller-Compactor (2~10 Ton) [720 h]; Operator - Roller-Compactor (2~10 Ton) [720 h] | 10,387.14 | OK | 1.3.5.80 | CONS | CONS | ZONE-4 | COMM |
| CON-Z4-UTIL-COM-0230 |  | Testing and Precommissioning of LV Cables for Camera | 12d | 2017-09-27 | 2017-10-11 | CON-Z4-UTIL-COM-0220, CON-Z4-UTIL-COM-0160 SS | 0.6d | 0d |  | 6,924.76 | OK | 1.3.5.80 | CONS | CONS | ZONE-4 | COMM |
|  | 2 | **Manholes and Duct Banks** |  | 2017-06-21 | 2017-07-31 |  |  |  |  |  |  |  |  |  |  |  |
| CON-Z4-UTIL-COM-0240 |  | Remaining Works for Construction of Communication Manholes and Duct Banks | 30d | 2017-06-21 | 2017-07-31 | CON-Z4-UTIL-COM-0170 SS | 61.4d | 2.4d | Shuttering Carpenter [300 h]; Concrete Mason [300 h]; Common Labor / Helper [300 h] | 23,082.54 | OK | 1.3.5.80 | CONS | CONS | ZONE-4 | COMM |
|  | 3 | **Installation of Foundations for Pole of CCTV Camera** |  | 2017-06-24 | 2017-08-06 |  |  |  |  |  |  |  |  |  |  |  |
| CON-Z4-UTIL-COM-0300 |  | Excavation of Foundations for Pole of CCTV Camera | 8d | 2017-06-24 | 2017-07-08 | CON-Z4-UTIL-COM-0240 SS, CON-Z4-UTIL-COM-0170 SS+2.4d | 59d | 0d | JCB [112 h]; Operator - JCB [80 h] | 9,233.02 | OK | 1.3.5.80 | CONS | CONS | ZONE-4 | COMM |
| CON-Z4-UTIL-COM-0310 |  | Compaction and Lean Concrete | 8d | 2017-07-02 | 2017-07-11 | CON-Z4-UTIL-COM-0300 SS+2.4d | 59d | 0d | Concrete Mason [80 h] | 4,616.51 | OK | 1.3.5.80 | CONS | CONS | ZONE-4 | COMM |
| CON-Z4-UTIL-COM-0320 |  | Concrete Work for Foundations With Anchor Bolts | 16d | 2017-07-04 | 2017-07-23 | CON-Z4-UTIL-COM-0310 SS+2.4d | 59d | 0d | Concrete Mason [160 h]; Shuttering Carpenter [160 h]; Steel Fixer [160 h] | 18,466.03 | OK | 1.3.5.80 | CONS | CONS | ZONE-4 | COMM |
| CON-Z4-UTIL-COM-0330 |  | Installation of Poles for CCTV Camera | 26d | 2017-07-08 | 2017-08-06 | CON-Z4-UTIL-COM-0320 SS+2.4d | 59d | 0d |  | 13,849.52 | OK | 1.3.5.80 | CONS | CONS | ZONE-4 | COMM |
|  | 4 | **Installation of Field Equipment Cabinet (FEC) and CCTV Camera** |  | 2017-07-08 | 2017-07-31 |  |  |  |  |  |  |  |  |  |  |  |
| CON-Z4-UTIL-COM-0340 |  | Instalaltion of CCTV Fied Equipment Cabinet (FEC) (07 No.) | 12d | 2017-07-08 | 2017-07-20 | CON-Z4-UTIL-COM-0330 SS | 59d | 0d |  | 13,849.52 | OK | 1.3.5.80 | CONS | CONS | ZONE-4 | COMM |
| CON-Z4-UTIL-COM-0350 |  | Installation of Fixed Camera (14 No.) | 18d | 2017-07-11 | 2017-07-31 | CON-Z4-UTIL-COM-0340 SS+3d | 59d | 0d |  | 34,623.81 | OK | 1.3.5.80 | CONS | CONS | ZONE-4 | COMM |
| CON-Z4-UTIL-COM-0360 |  | Installation of Pole Camera (7 No.) | 12d | 2017-07-15 | 2017-07-27 | CON-Z4-UTIL-COM-0350 SS+3d | 59d | 0d |  | 20,774.29 | OK | 1.3.5.80 | CONS | CONS | ZONE-4 | COMM |
|  | 5 | **Internal Cabling System for CCTV** |  | 2017-07-18 | 2017-11-01 |  |  |  |  |  |  |  |  |  |  |  |
| CON-Z4-UTIL-COM-0370 |  | Installation and Termination of Coaxial Cables from FEC to Camera | 12d | 2017-07-18 | 2017-07-31 | CON-Z4-UTIL-COM-0360 SS+3d | 59d | 0d |  | 6,924.76 | OK | 1.3.5.80 | CONS | CONS | ZONE-4 | COMM |
| CON-Z4-UTIL-COM-0380 |  | Instalaltion and Termination of Copper Control Cables for PTZ Camera | 12d | 2017-07-22 | 2017-08-03 | CON-Z4-UTIL-COM-0370 SS+3d | 59d | 0d |  | 6,924.76 | OK | 1.3.5.80 | CONS | CONS | ZONE-4 | COMM |
| CON-Z4-UTIL-COM-0390 |  | FOC Splicing | 4d | 2017-07-25 | 2017-07-29 | CON-Z4-UTIL-COM-0380 SS+3d | 59d | 58.4d |  | 4,616.51 | OK | 1.3.5.80 | CONS | CONS | ZONE-4 | COMM |
| CON-Z4-UTIL-COM-0400 |  | Testing & Precommissioning of Communication & Security Systrems of Zone 4 | 18d | 2017-10-11 | 2017-11-01 | CON-Z4-UTIL-COM-0390, CON-Z4-UTIL-COM-0040, CON-Z4-UTIL-COM-0230 | 0.6d | 0.2d | LC Crew [360 h]; Electrician [900 h] | 4,616.51 | OK | 1.3.5.80 | CONS | CONS | ZONE-4 | COMM |

Notes:
- CON-Z4-UTIL-COM-0170: Expenses: (New Expense Item) 6924.76
- CON-Z4-UTIL-COM-0180: Expenses: (New Expense Item) 6924.76
- CON-Z4-UTIL-COM-0190: Expenses: (New Expense Item) 20774.3
- CON-Z4-UTIL-COM-0200: Expenses: (New Expense Item) 3462.38
- CON-Z4-UTIL-COM-0210: Expenses: (New Expense Item) 13849.5
- CON-Z4-UTIL-COM-0220: Expenses: (New Expense Item) 10387.1
- CON-Z4-UTIL-COM-0230: Expenses: (New Expense Item) 6924.76
- CON-Z4-UTIL-COM-0240: Expenses: (New Expense Item) 23082.5
- CON-Z4-UTIL-COM-0300: Expenses: (New Expense Item) 9233.02
- CON-Z4-UTIL-COM-0310: Expenses: (New Expense Item) 4616.51
- CON-Z4-UTIL-COM-0320: Expenses: (New Expense Item) 18466
- CON-Z4-UTIL-COM-0330: Expenses: (New Expense Item) 13849.5
- CON-Z4-UTIL-COM-0340: Expenses: (New Expense Item) 13849.5
- CON-Z4-UTIL-COM-0350: Expenses: (New Expense Item) 34623.8
- CON-Z4-UTIL-COM-0360: Expenses: (New Expense Item) 20774.3
- CON-Z4-UTIL-COM-0370: Expenses: (New Expense Item) 6924.76
- CON-Z4-UTIL-COM-0380: Expenses: (New Expense Item) 6924.76
- CON-Z4-UTIL-COM-0390: Expenses: (New Expense Item) 4616.51
- CON-Z4-UTIL-COM-0400: Expenses: (New Expense Item) 4616.51

| ID | WBS | Activity | Type | Duration | Start | Finish | Predecessors | Total float | Free float | Resources | Cost | Activity Wt% | Weight % | Cost Wt | RPI - PHASE | RPI - CONSTRUCTION | RPI - ZONES | RPI - BUILDINGS | RPI - TYPE OF WORK | RPI_P2 - BOQ ITEMS | RPI_P2 - CONSTRUCTION | RPI_P2 - PHASE | RPI_P2 - ZONES | RPI_P2 - BUILDINGS |
| --- | --- | --- | --- | --- | --- | --- | --- | --- | --- | --- | --- | --- | --- | --- | --- | --- | --- | --- | --- | --- | --- | --- | --- | --- |
|  | 2 | **BUILDING WORKS** |  |  | 2017-01-03 | 2017-08-03 |  |  |  |  |  |  |  |  |  |  |  |  |  |  |  |  |  |  |
|  | 2 | **Lift Station no. 9** |  |  | 2017-01-03 | 2017-08-03 |  |  |  |  |  |  |  |  |  |  |  |  |  |  |  |  |  |  |
|  | 1 | **Lift Station no. 9 & ATS Room for Lift Station** |  |  | 2017-01-03 | 2017-08-03 |  |  |  |  |  |  |  |  |  |  |  |  |  |  |  |  |  |  |
|  | 1 | **Civil & Structural Works** |  |  | 2017-01-03 | 2017-03-16 |  |  |  |  |  |  |  |  |  |  |  |  |  |  |  |  |  |  |
|  | 1 | **Liftstation No. 9** |  |  | 2017-01-03 | 2017-02-22 |  |  |  |  |  |  |  |  |  |  |  |  |  |  |  |  |  |  |
| CON-Z4-LS9-SW-0010 |  | Start of Work for Lift Station # 9 | milestone | 0d | 2017-01-03 | 2017-01-03 | CON-Z3-LS10-SW-0000 FS+26d | 31.4d | 0d |  |  | 0 | 0 | 0 | 6 | RPI - CONS | Z2 | LS12 | CIVIL | 1.3.6.10 | CONS | CONS | ZONE-4 | LS-9 |
| CON-Z4-LS9-SW-0020 |  | Dewatering for Lift Station # 9 |  | 8d | 2017-01-03 | 2017-01-12 | CON-Z4-LS9-SW-0010 | 31.4d | 0d | Common Labor / Helper [104 h] | 1,000 |  |  |  |  |  |  |  |  | 1.3.6.10 | CONS | CONS | ZONE-4 | LS-9 |
| CON-Z4-LS9-SW-0040 |  | Concrete Columns / Walls - Steel / Formwork & Concrete above Lift Station # 9 |  | 6.4d | 2017-01-12 | 2017-01-21 | PR-Z3-CW-CW-24-0080, CON-Z4-LS9-SW-0020 | 31.4d | 0d | Steel Fixer [78 h]; Shuttering Carpenter [78 h]; Concrete Mason [78 h]; Common Labor / Helper [52 h]; Scaffolder [52 h]; Driver - Conc. Transit Mixers [26 h]; Operator - Concrete Pump [26 h]; Concrete Transit Mixers [28 h]; Concrete Pump [28 h] | 13,247.96 | 0 | 0 | 0.1338573317 | 6 | RPI - CONS | Z2 | LS12 | CIVIL | 1.3.6.10 | CONS | CONS | ZONE-4 | LS-9 |
| CON-Z4-LS9-SW-0050 |  | Roof Slab - Shuttering, Steel, Formwork & Concrete above Lift Station # 9 |  | 7.2d | 2017-01-21 | 2017-01-29 | CON-Z4-LS9-SW-0040 | 31.4d | 0d | Steel Fixer [52 h]; Shuttering Carpenter [78 h]; Concrete Mason [78 h]; Common Labor / Helper [78 h]; Scaffolder [78 h] | 6,512.08 | 0 | 0 | 0.0561098933 | 6 | RPI - CONS | Z2 | LS12 | CIVIL | 1.3.6.10 | CONS | CONS | ZONE-4 | LS-9 |
| CON-Z4-LS9-SW-0080 |  | Water Proofing roofing system for the roof |  | 4.8d | 2017-02-04 | 2017-02-08 | CON-Z4-LS9-SW-0050 FS+4.8d | 40.2d | 8.8d | Water Proofing Crew [52 h] | 13,099.01 | 0 | 0 | 0.046823408 | 6 | RPI - CONS | Z2 | LS12 | CIVIL | 1.3.6.10 | CONS | CONS | ZONE-4 | LS-9 |
| CON-Z4-LS9-SW-0060 |  | De-shuttering Roof Slab |  | 2.4d | 2017-02-05 | 2017-02-07 | CON-Z4-LS9-SW-0050 FS+5.6d | 64d | 0d | Shuttering Carpenter [78 h]; Scaffolder [52 h] | 500 | 0 | 0 | 0.0010581949 | 6 | RPI - CONS | Z2 | LS12 | CIVIL | 1.3.6.10 | CONS | CONS | ZONE-4 | LS-9 |
| CON-Z4-LS9-SW-0070 |  | Surface Preparation / External Water proofing for wall |  | 7.2d | 2017-02-05 | 2017-02-13 | CON-Z4-LS9-SW-0050 FS+6.4d | 31.4d | 0d | Common Labor / Helper [52 h]; Scaffolder [52 h]; Water Proofing Crew [52 h]; Finishing Work Crew [52 h]; Roller-Compactor (2~10 Ton) [100.8 h]; JCB [100.8 h] | 2,124.19 | 0 | 0 | 0.4514238297 | 6 | RPI - CONS | Z2 | LS12 | CIVIL | 1.3.6.10 | CONS | CONS | ZONE-4 | LS-9 |
| CON-Z4-LS9-SW-0090 |  | Backfilling around Lift Station # 9 |  | 7.2d | 2017-02-14 | 2017-02-22 | CON-Z4-LS9-SW-0080 SS, CON-Z4-LS9-SW-0070 | 31.4d | 0d | Common Labor / Helper [78 h]; Operator - Loader [26 h]; Driver - Dump Truck [26 h]; Operator - Bobcat [26 h]; Operator - Roller-Compactor (2~10 Ton) [26 h]; Operator - Roller (25 Ton) [26 h]; Driver - Water Tanker [26 h]; Loader [28 h]; Dump Truck [28 h]; Bobcat [28 h]; Roller-Compactor (2~10 Ton) [28 h]; Roller-Compactor (25 Ton) [28 h]; Water Tanker [28 h] | 10,915.57 | 0 | 0 | 0.0442654971 | 6 | RPI - CONS | Z2 | LS12 | CIVIL | 1.3.6.10 | CONS | CONS | ZONE-4 | LS-9 |
|  | 2 | **ATS Room for Lift Station No. 9** |  |  | 2017-01-21 | 2017-03-16 |  |  |  |  |  |  |  |  |  |  |  |  |  |  |  |  |  |  |
| CON-Z4-ATSR-CW-0010 |  | Excavation / Grade Beam Excavation |  | 3.2d | 2017-01-21 | 2017-01-24 | CON-Z4-LS9-SW-0040 | 46.6d | 0d | Operator - Excavator [26 h]; JCB [28 h] | 229.39 | 0 | 0 | 0.0004854786 | 6 | RPI - CONS | Z2 | LS12 | CIVIL | 1.3.6.10 | CONS | CONS | ZONE-4 | LS-9 |
| CON-Z4-ATSR-CW-0020 |  | Bed Preparation / Lean Concrete |  | 1.6d | 2017-01-24 | 2017-01-25 | CON-Z4-ATSR-CW-0010 | 46.6d | 0d | Concrete Mason [52 h]; Driver - Conc. Transit Mixers [26 h]; Operator - Concrete Pump [26 h] | 351.87 | 0 | 0 | 0.000744694 | 6 | RPI - CONS | Z2 | LS12 | CIVIL | 1.3.6.10 | CONS | CONS | ZONE-4 | LS-9 |
| CON-Z4-ATSR-CW-0030 |  | RC Footing |  | 4d | 2017-01-26 | 2017-01-30 | CON-Z4-ATSR-CW-0020 | 46.6d | 0d | Steel Fixer [78 h]; Shuttering Carpenter [78 h]; Concrete Mason [78 h]; Mechanical Technician [52 h] | 2,185.22 | 0 | 0 | 0.0046247771 | 6 | RPI - CONS | Z2 | LS12 | CIVIL | 1.3.6.10 | CONS | CONS | ZONE-4 | LS-9 |
| CON-Z4-ATSR-CW-0040 |  | Lean Concrete - grade beam |  | 0.8d | 2017-01-31 | 2017-01-31 | CON-Z4-ATSR-CW-0030 | 46.6d | 0d | Concrete Mason [52 h]; Driver - Conc. Transit Mixers [26 h]; Operator - Concrete Pump [26 h] | 195.48 | 0 | 0 | 0.0004137119 | 6 | RPI - CONS | Z2 | LS12 | CIVIL | 1.3.6.10 | CONS | CONS | ZONE-4 | LS-9 |
| CON-Z4-ATSR-CW-0050 |  | Concrete Apron / Grade Beam |  | 3.2d | 2017-01-31 | 2017-02-04 | CON-Z4-ATSR-CW-0040 | 46.6d | 15.2d | Steel Fixer [52 h]; Shuttering Carpenter [78 h]; Concrete Mason [78 h]; Common Labor / Helper [52 h] | 4,489.68 | 0 | 0 | 0.0095019125 | 6 | RPI - CONS | Z2 | LS12 | CIVIL | 1.3.6.10 | CONS | CONS | ZONE-4 | LS-9 |
| CON-Z4-ATSR-CW-0060 |  | Backfilling / Compaction & Testing |  | 2.4d | 2017-02-22 | 2017-02-25 | CON-Z4-LS9-SW-0090, CON-Z4-ATSR-CW-0050 | 31.4d | 0d | Common Labor / Helper [78 h]; Operator - Loader [26 h]; Driver - Dump Truck [26 h]; Operator - Bobcat [26 h]; Operator - Roller-Compactor (2~10 Ton) [26 h]; Operator - Roller (25 Ton) [26 h]; Driver - Water Tanker [26 h]; Loader [28 h]; Dump Truck [28 h]; Bobcat [28 h]; Roller-Compactor (2~10 Ton) [28 h]; Roller-Compactor (25 Ton) [28 h]; Water Tanker [28 h] | 1,038.55 | 0 | 0 | 0.0021979765 | 6 | RPI - CONS | Z2 | LS12 | CIVIL | 1.3.6.10 | CONS | CONS | ZONE-4 | LS-9 |
| CON-Z4-ATSR-CW-0070 |  | Slab on grade |  | 3.2d | 2017-02-25 | 2017-02-28 | CON-Z4-ATSR-CW-0060 | 31.4d | 0d | Steel Fixer [52 h]; Shuttering Carpenter [78 h]; Concrete Mason [78 h]; Common Labor / Helper [78 h] | 2,119.3 | 0 | 0 | 0.0044852647 | 6 | RPI - CONS | Z2 | LS12 | CIVIL | 1.3.6.10 | CONS | CONS | ZONE-4 | LS-9 |
| CON-Z4-ATSR-CW-0080 |  | Concrete Columns |  | 4.8d | 2017-02-28 | 2017-03-06 | CON-Z4-ATSR-CW-0070 | 31.4d | 0d | Steel Fixer [78 h]; Shuttering Carpenter [78 h]; Concrete Mason [78 h]; Common Labor / Helper [52 h]; Scaffolder [52 h]; Driver - Conc. Transit Mixers [26 h]; Operator - Concrete Pump [26 h]; Concrete Transit Mixers [28 h]; Concrete Pump [28 h] | 1,976.65 | 0 | 0 | 0.0062997514 | 6 | RPI - CONS | Z2 | LS12 | CIVIL | 1.3.6.10 | CONS | CONS | ZONE-4 | LS-9 |
| CON-Z4-ATSR-CW-0090 |  | Beams & Roof Slab |  | 5.6d | 2017-03-06 | 2017-03-13 | CON-Z4-ATSR-CW-0080 | 31.4d | 0d | Steel Fixer [52 h]; Shuttering Carpenter [78 h]; Concrete Mason [78 h]; Common Labor / Helper [78 h]; Scaffolder [78 h] | 6,182.91 | 0 | 0 | 0.0130854471 | 6 | RPI - CONS | Z2 | LS12 | CIVIL | 1.3.6.10 | CONS | CONS | ZONE-4 | LS-9 |
| CON-Z4-ATSR-CW-0100 |  | Parapet Walls |  | 3.2d | 2017-03-13 | 2017-03-16 | CON-Z4-ATSR-CW-0090 | 31.4d | 0d | Steel Fixer [52 h]; Shuttering Carpenter [78 h]; Concrete Mason [52 h]; Common Labor / Helper [52 h]; Scaffolder [52 h] | 1,960.22 | 0 | 0 | 0.0041485894 | 6 | RPI - CONS | Z2 | LS12 | CIVIL | 1.3.6.10 | CONS | CONS | ZONE-4 | LS-9 |

Notes:
- CON-Z4-LS9-SW-0020: Expenses: (New Expense Item) 1000
- CON-Z4-LS9-SW-0040: Expenses: (New Expense Item) 13248
- CON-Z4-LS9-SW-0050: Expenses: (New Expense Item) 6512.08
- CON-Z4-LS9-SW-0080: Expenses: (New Expense Item) 13099
- CON-Z4-LS9-SW-0060: Expenses: (New Expense Item) 500
- CON-Z4-LS9-SW-0070: Expenses: (New Expense Item) 2124.19
- CON-Z4-LS9-SW-0090: Expenses: (New Expense Item) 10915.6
- CON-Z4-ATSR-CW-0010: Expenses: (New Expense Item) 229.39
- CON-Z4-ATSR-CW-0020: Expenses: (New Expense Item) 351.87
- CON-Z4-ATSR-CW-0030: Expenses: (New Expense Item) 2185.22
- CON-Z4-ATSR-CW-0040: Expenses: (New Expense Item) 195.48
- CON-Z4-ATSR-CW-0050: Expenses: (New Expense Item) 4489.68
- CON-Z4-ATSR-CW-0060: Expenses: (New Expense Item) 1038.55
- CON-Z4-ATSR-CW-0070: Expenses: (New Expense Item) 2119.3
- CON-Z4-ATSR-CW-0080: Expenses: (New Expense Item) 1976.65
- CON-Z4-ATSR-CW-0090: Expenses: (New Expense Item) 6182.91
- CON-Z4-ATSR-CW-0100: Expenses: (New Expense Item) 1960.22

| ID | WBS | Activity | Duration | Start | Finish | Predecessors | Total float | Free float | Resources | Cost | Activity Wt% | Weight % | Cost Wt | RPI - PHASE | RPI - CONSTRUCTION | RPI - ZONES | RPI - BUILDINGS | RPI - TYPE OF WORK | RPI_P2 - BOQ ITEMS | RPI_P2 - CONSTRUCTION | RPI_P2 - PHASE | RPI_P2 - ZONES | RPI_P2 - BUILDINGS |
| --- | --- | --- | --- | --- | --- | --- | --- | --- | --- | --- | --- | --- | --- | --- | --- | --- | --- | --- | --- | --- | --- | --- | --- |
|  | 2 | **Architectural Works & Finishes** |  | 2017-02-14 | 2017-04-13 |  |  |  |  |  |  |  |  |  |  |  |  |  |  |  |  |  |  |
|  | 1 | **Liftstation No. 9** |  | 2017-02-14 | 2017-03-13 |  |  |  |  |  |  |  |  |  |  |  |  |  |  |  |  |  |  |
| CON-Z4-LS9-AR-0010 |  | Surface Preparation / Epoxy paint for the wall (Dry & Wet Well) | 16.8d | 2017-02-14 | 2017-03-05 | CON-Z4-LS9-SW-0070 | 41d | 0d | Common Labor / Helper [26 h]; Scaffolder [52 h]; Painter [78 h] | 9,779.52 | 0 | 0 | 0.0630250697 | 6 | RPI - CONS | Z2 | LS12 | CIVIL | 1.3.6.10 | CONS | CONS | ZONE-4 | LS-9 |
| CON-Z4-LS9-AR-0020 |  | Surface Preparation / Non Skid epoxy paint for the floor (Dry & Wet Well) | 9.6d | 2017-02-25 | 2017-03-08 | CON-Z4-LS9-AR-0010 SS+9.6d | 41d | 0d | Common Labor / Helper [26 h]; Scaffolder [52 h]; Painter [78 h] | 7,624.83 | 0 | 0 | 0.0373010088 | 6 | RPI - CONS | Z2 | LS12 | CIVIL | 1.3.6.10 | CONS | CONS | ZONE-4 | LS-9 |
| CON-Z4-LS9-AR-0030 |  | Wall & Ceiling paint for the room above LS | 6.4d | 2017-03-05 | 2017-03-13 | CON-Z4-LS9-AR-0020 FF+4d | 41d | 0d | Common Labor / Helper [26 h]; Scaffolder [52 h]; Painter [78 h]; Gypsum Walls & Ceiling Crew [52 h] | 4,542.41 | 0 | 0 | 0.051941304 | 6 | RPI - CONS | Z2 | LS12 | CIVIL | 1.3.6.10 | CONS | CONS | ZONE-4 | LS-9 |
| CON-Z4-LS9-AR-0040 |  | Installation of door frames & doors | 4.8d | 2017-03-05 | 2017-03-11 | CON-Z4-LS9-AR-0030 SS | 41d | 0d | Shuttering Carpenter [52 h]; Common Labor / Helper [26 h] | 8,751.92 | 0 | 0 | 0.0185224734 | 6 | RPI - CONS | Z2 | LS12 | CIVIL | 1.3.6.10 | CONS | CONS | ZONE-4 | LS-9 |
| CON-Z4-LS9-AR-0050 |  | Cage Ladder FRP | 3.2d | 2017-03-05 | 2017-03-08 | CON-Z4-LS9-AR-0040 SS | 41d | 9.6d | Common Labor / Helper [104 h] | 9,723.46 | 0 | 0 | 0.0861867117 | 6 | RPI - CONS | Z2 | LS12 | CIVIL | 1.3.6.10 | CONS | CONS | ZONE-4 | LS-9 |
|  | 2 | **ATS Room for Lift Station No. 9** |  | 2017-03-16 | 2017-04-13 |  |  |  |  |  |  |  |  |  |  |  |  |  |  |  |  |  |  |
| CON-Z4-LS9-AR-0060 |  | Block Works | 6.4d | 2017-03-16 | 2017-03-23 | CON-Z4-ATSR-CW-0100, CON-Z4-LS9-AR-0050 SS | 31.4d | 0d | Common Labor / Helper [52 h]; Block Mason [78 h] | 5,131.47 | 0 | 0 | 0.0108601903 | 6 | RPI - CONS | Z2 | LS12 | CIVIL | 1.3.6.10 | CONS | CONS | ZONE-4 | LS-9 |
| CON-Z4-LS9-AR-0070 |  | Plastering - Internal & External | 5.6d | 2017-03-23 | 2017-03-30 | CON-Z4-LS9-AR-0060 | 31.4d | 0d | Concrete Mason [78 h]; Common Labor / Helper [26 h]; Scaffolder [26 h]; Finishing Work Crew [52 h] | 7,697.2 | 0 | 0 | 0.0162902749 | 6 | RPI - CONS | Z2 | LS12 | CIVIL | 1.3.6.10 | CONS | CONS | ZONE-4 | LS-9 |
| CON-Z4-LS9-AR-0080 |  | Internal Painting | 5.6d | 2017-03-30 | 2017-04-05 | CON-Z4-LS9-AR-0070 | 31.4d | 0d | Common Labor / Helper [26 h]; Scaffolder [52 h]; Painter [78 h] | 5,375.22 | 0 | 0 | 0.0072401269 | 6 | RPI - CONS | Z2 | LS12 | CIVIL | 1.3.6.10 | CONS | CONS | ZONE-4 | LS-9 |
| CON-Z4-LS9-AR-0090 |  | External Painting | 6.4d | 2017-03-30 | 2017-04-06 | CON-Z4-LS9-AR-0070 | 94.6d | 0d | Common Labor / Helper [26 h]; Scaffolder [52 h]; Painter [78 h] | 6,407.55 | 0 | 0 | 0.0113760603 | 6 | RPI - CONS | Z2 | LS12 | CIVIL | 1.3.6.10 | CONS | CONS | ZONE-4 | LS-9 |
| CON-Z4-LS9-AR-0100 |  | Doors & Windows | 2.4d | 2017-04-06 | 2017-04-10 | CON-Z4-LS9-AR-0090, CON-Z4-LS9-AR-0070 | 94.6d | 0d | Shuttering Carpenter [52 h]; Common Labor / Helper [26 h] | 3,420.98 | 0 | 0 | 0.0135608729 | 6 | RPI - CONS | Z2 | LS12 | CIVIL | 1.3.6.10 | CONS | CONS | ZONE-4 | LS-9 |
| CON-Z4-LS9-AR-0120 |  | Roofing System | 4d | 2017-04-06 | 2017-04-11 | CON-Z4-LS9-AR-0090 | 97d | 51.4d | Common Labor / Helper [52 h]; Water Proofing Crew [52 h]; Finishing Work Crew [52 h] | 794.16 | 0 | 0 | 0.0182224117 | 6 | RPI - CONS | Z2 | LS12 | CIVIL | 1.3.6.10 | CONS | CONS | ZONE-4 | LS-9 |
| CON-Z4-LS9-AR-0110 |  | Floor Finishes | 3.2d | 2017-04-10 | 2017-04-13 | CON-Z4-LS9-AR-0080, CON-Z4-LS9-AR-0100 | 94.6d | 49d | Common Labor / Helper [52 h]; Finishing Work Crew [52 h] | 8,610.14 | 0 | 0 | 0.0016807521 | 6 | RPI - CONS | Z2 | LS12 | CIVIL | 1.3.6.10 | CONS | CONS | ZONE-4 | LS-9 |
|  | 3 | **Mechanical Works** |  | 2017-02-07 | 2017-07-02 |  |  |  |  |  |  |  |  |  |  |  |  |  |  |  |  |  |  |
|  | 1 | **Liftstation No. 9** |  | 2017-02-07 | 2017-04-15 |  |  |  |  |  |  |  |  |  |  |  |  |  |  |  |  |  |  |
| CON-Z4-LS9-ME-0040 |  | Installation of Plumbing Works | 11.2d | 2017-02-07 | 2017-02-20 | CON-Z4-LS9-SW-0060 | 145d | 0d | Plumber [52 h]; Common Labor / Helper [26 h] | 20,886.35 | 0 | 0 | 0.2558426271 | 6 | RPI - CONS | Z2 | LS12 | MECH | 1.3.6.10 | CONS | CONS | ZONE-4 | LS-9 |
| CON-Z4-LS9-ME-0050 |  | Tie-in for Water Supply | 14.4d | 2017-02-19 | 2017-03-07 | CON-Z4-LS9-ME-0040 SS+9.6d | 145d | 0d | Plumber [52 h]; Common Labor / Helper [52 h] | 13,181.8 | 0 | 0 | 0.0852808757 | 6 | RPI - CONS | Z2 | LS12 | MECH | 1.3.6.10 | CONS | CONS | ZONE-4 | LS-9 |
| CON-Z4-LS9-ME-0010 |  | Installation of pumps & Disconnection Switches at Pump Room Area | 20d | 2017-02-28 | 2017-03-23 | CON-Z4-LS9-SW-0060, PR-Z4-CW-CW-172-0080 | 45.6d | 0d | Electrician [78 h]; Mechanical Technician [26 h]; Operator - Mobile Crane [26 h]; Mobile Crane ( 25-60 Ton) [28 h] | 20,886.35 | 0 | 0 | 0.5116852542 | 6 | RPI - CONS | Z2 | LS12 | MECH | 1.3.6.10 | CONS | CONS | ZONE-4 | LS-9 |
| CON-Z4-LS9-ME-0020 |  | Installation of Valves | 16.8d | 2017-03-23 | 2017-04-12 | CON-Z4-LS9-ME-0010 | 45.6d | 0d | Common Labor / Helper [26 h]; RTR Pipe Crew [26 h] | 241,772.7 | 0 | 0 | 0.1705617514 | 6 | RPI - CONS | Z2 | LS12 | MECH | 1.3.6.10 | CONS | CONS | ZONE-4 | LS-9 |
| CON-Z4-LS9-ME-0030 |  | Installation of Odor control system in Pump Room Area | 14.4d | 2017-03-23 | 2017-04-10 | PR-Z3-GE-GE-237-0080, CON-Z4-LS9-ME-0020 SS | 45.6d | 0d | Mechanical Technician [26 h]; Common Labor / Helper [52 h]; HVAC Crew [26 h]; Specialist Works Crew [26 h] | 80,590.9 | 0 | 0 | 0.2558426271 | 6 | RPI - CONS | Z2 | LS12 | MECH | 1.3.6.10 | CONS | CONS | ZONE-4 | LS-9 |
| CON-Z4-LS9-ME-0060 |  | Installation of Lifting Hoist with Chain in LS-9 | 4d | 2017-04-10 | 2017-04-15 | CON-Z4-LS9-ME-0030 | 45.6d | 0d | Common Labor / Helper [78 h]; Scaffolder [52 h]; Operator - Mobile Crane [26 h]; Mobile Crane ( 25-60 Ton) [28 h] |  |  |  |  |  |  |  |  |  | 1.3.6.10 | CONS | CONS | ZONE-4 | LS-9 |
|  | 2 | **ATS Room for Lift Station No. 9** |  | 2017-06-06 | 2017-07-02 |  |  |  |  |  |  |  |  |  |  |  |  |  |  |  |  |  |  |
| CON-Z4-LS9-ME-0070 |  | Installation of two Package Air Conditioning Units | 16.8d | 2017-06-06 | 2017-06-25 | CON-Z4-LS9-AR-0120 SS, PR-Z3-GE-GE-242-0080, CON-Z4-LS9-ME-0060 FS+45d, CON-Z4-LS9-AR-0110 SS | 45.6d | 0d | HVAC Crew [26 h] | 120,886.35 | 0 | 0 | 0.2558426271 | 6 | RPI - CONS | Z2 | LS12 | MECH | 1.3.6.10 | CONS | CONS | ZONE-4 | LS-9 |
| CON-Z4-LS9-ME-0080 |  | Installation of DDC Panels inside ATS Rooms | 14.4d | 2017-06-11 | 2017-07-02 | CON-Z4-LS9-ME-0070 SS+4d | 45.6d | 0d | Electrician [52 h]; Specialist Works Crew [26 h] | 40,295.45 | 0 | 0 | 0.0852808757 | 6 | RPI - CONS | Z2 | LS12 | MECH | 1.3.6.10 | CONS | CONS | ZONE-4 | LS-9 |

Notes:
- CON-Z4-LS9-AR-0010: Expenses: (New Expense Item) 9779.52
- CON-Z4-LS9-AR-0020: Expenses: (New Expense Item) 7624.83
- CON-Z4-LS9-AR-0030: Expenses: (New Expense Item) 4542.41
- CON-Z4-LS9-AR-0040: Expenses: (New Expense Item) 8751.92
- CON-Z4-LS9-AR-0050: Expenses: (New Expense Item) 9723.46
- CON-Z4-LS9-AR-0060: Expenses: (New Expense Item) 5131.47
- CON-Z4-LS9-AR-0070: Expenses: (New Expense Item) 7697.2
- CON-Z4-LS9-AR-0080: Expenses: (New Expense Item) 5375.22
- CON-Z4-LS9-AR-0090: Expenses: (New Expense Item) 6407.55
- CON-Z4-LS9-AR-0100: Expenses: (New Expense Item) 3420.98
- CON-Z4-LS9-AR-0120: Expenses: (New Expense Item) 794.16
- CON-Z4-LS9-AR-0110: Expenses: (New Expense Item) 8610.14
- CON-Z4-LS9-ME-0040: Expenses: (New Expense Item) 20886.3
- CON-Z4-LS9-ME-0050: Expenses: (New Expense Item) 13181.8
- CON-Z4-LS9-ME-0010: Expenses: (New Expense Item) 20886.3
- CON-Z4-LS9-ME-0020: Expenses: (New Expense Item) 241773
- CON-Z4-LS9-ME-0030: Expenses: (New Expense Item) 80590.9
- CON-Z4-LS9-ME-0070: Expenses: (New Expense Item) 120886
- CON-Z4-LS9-ME-0080: Expenses: (New Expense Item) 40295.4

| ID | WBS | Activity | Duration | Start | Finish | Predecessors | Total float | Free float | Resources | Cost | Activity Wt% | Weight % | Cost Wt | RPI - PHASE | RPI - CONSTRUCTION | RPI - ZONES | RPI - BUILDINGS | RPI - TYPE OF WORK | RPI_P2 - BOQ ITEMS | RPI_P2 - CONSTRUCTION | RPI_P2 - PHASE | RPI_P2 - ZONES | RPI_P2 - BUILDINGS |
| --- | --- | --- | --- | --- | --- | --- | --- | --- | --- | --- | --- | --- | --- | --- | --- | --- | --- | --- | --- | --- | --- | --- | --- |
|  | 4 | **Electrical Works** |  | 2017-04-06 | 2017-06-05 |  |  |  |  |  |  |  |  |  |  |  |  |  |  |  |  |  |  |
|  | 1 | **Liftstation No. 9** |  | 2017-04-06 | 2017-05-22 |  |  |  |  |  |  |  |  |  |  |  |  |  |  |  |  |  |  |
| CON-Z4-LS9-ELE-0010 |  | Installation of Conduits, Race Ways, Junction Boxes | 20.8d | 2017-04-06 | 2017-04-30 | CON-Z4-LS9-AR-0080 | 31.4d | 0d | Electrician [78 h]; LC Crew [52 h] | 17,441 | 0 | 0 | 0.0369119529 | 6 | RPI - CONS | Z2 | LS12 | ELEC | 1.3.6.10 | CONS | CONS | ZONE-4 | LS-9 |
| CON-Z4-LS9-ELE-0020 |  | LV / MV Cables & Wire Pulling | 16.8d | 2017-04-11 | 2017-05-01 | CON-Z4-LS9-ELE-0010 SS+4.8d | 80.2d | 0d | Electrician [78 h]; LC Crew [52 h] | 31,946.8 | 0 | 0 | 0.0676118788 | 6 | RPI - CONS | Z2 | LS12 | ELEC | 1.3.6.10 | CONS | CONS | ZONE-4 | LS-9 |
| CON-Z4-LS9-ELE-0050 |  | Installation of Ultrasonic Level Sensor / Controller at LS-9 | 20d | 2017-04-13 | 2017-05-07 | CON-Z4-LS9-ELE-0020 SS+1.6d | 89.8d | 44.2d | Electrician [78 h]; LC Crew [52 h] | 52,323 | 0 | 0 | 0.0128180201 | 6 | RPI - CONS | Z2 | LS12 | ELEC | 1.3.6.10 | CONS | CONS | ZONE-4 | LS-9 |
| CON-Z4-LS9-ELE-0030 |  | Installation of LV Panel Boards, Equipments | 20d | 2017-04-17 | 2017-05-10 | CON-Z4-LS9-ELE-0020 SS+4.8d | 80.2d | 0d | Electrician [78 h]; LC Crew [52 h] | 6,056.55 | 0 | 0 | 0.0738239058 | 6 | RPI - CONS | Z2 | LS12 | ELEC | 1.3.6.10 | CONS | CONS | ZONE-4 | LS-9 |
| CON-Z4-LS9-ELE-0040 |  | Installation of Wiring Devices, Outlets, Switches , Lighting Fixtures | 20d | 2017-04-29 | 2017-05-22 | CON-Z4-LS9-ELE-0030 SS+9.6d | 80.2d | 0d | Electrician [78 h]; LC Crew [52 h] | 34,882 | 0 | 0 | 0.1107358588 | 6 | RPI - CONS | Z2 | LS12 | ELEC | 1.3.6.10 | CONS | CONS | ZONE-4 | LS-9 |
| CON-Z4-LS9-ELE-0060 |  | Installation of Audible Alarm on Lift Station | 16.8d | 2017-04-29 | 2017-05-17 | CON-Z4-LS9-ELE-0040 SS, CON-Z4-LS9-ELE-0030 SS | 80.2d | 34.6d | Electrician [78 h]; LC Crew [52 h] | 3,560 | 0 | 0 | 0.0075343474 | 6 | RPI - CONS | Z2 | LS12 | ELEC | 1.3.6.10 | CONS | CONS | ZONE-4 | LS-9 |
|  | 2 | **ATS Room for Lift Station No. 9** |  | 2017-04-30 | 2017-06-05 |  |  |  |  |  |  |  |  |  |  |  |  |  |  |  |  |  |  |
| CON-Z4-LS9-ELE-0070 |  | Installation of Cable ways, Conduits, Boxes (for Power & Control Cables) | 9.6d | 2017-04-30 | 2017-05-11 | CON-Z4-LS9-AR-0080, CON-Z4-LS9-ELE-0010 | 31.4d | 0d | Electrician [78 h]; LC Crew [52 h] | 17,441 | 0 | 0 | 0.0369119529 | 6 | RPI - CONS | Z2 | LS12 | ELEC | 1.3.6.10 | CONS | CONS | ZONE-4 | LS-9 |
| CON-Z4-LS9-ELE-0080 |  | LV / MV Cables & Wire Pulling | 14.4d | 2017-05-06 | 2017-05-22 | CON-Z4-LS9-ELE-0070 SS+4.8d | 31.4d | 0d | Electrician [720 h]; LC Crew [144 h] | 31,946.8 | 0 | 0 | 0.0676118788 | 6 | RPI - CONS | Z2 | LS12 | ELEC | 1.3.6.10 | CONS | CONS | ZONE-4 | LS-9 |
| CON-Z4-LS9-ELE-0140 |  | Cable Dressing, Termination & Testing from Circuit Breaker to Motor Control Center | 14.4d | 2017-05-06 | 2017-05-22 | CON-Z4-LS9-ELE-0180 SS | 69.8d | 0d | Electrician [720 h]; LC Crew [144 h] | 3,993.35 | 0 | 0 | 0.0169029697 | 6 | RPI - CONS | Z2 | LS12 | ELEC | 1.3.6.10 | CONS | CONS | ZONE-4 | LS-9 |
| CON-Z4-LS9-ELE-0150 |  | Cable Dressing, Termination & Testing from ATS LS-9 to Emergency Generator | 14.4d | 2017-05-06 | 2017-05-22 | CON-Z4-LS9-ELE-0140 SS | 69.8d | 0d | Electrician [720 h]; LC Crew [144 h] | 13,567 | 0 | 0 | 0.0084514848 | 6 | RPI - CONS | Z2 | LS12 | ELEC | 1.3.6.10 | CONS | CONS | ZONE-4 | LS-9 |
| CON-Z4-LS9-ELE-0160 |  | Cable Dressing, Termination & Testing from MCC to Pumps thru Starter | 14.4d | 2017-05-06 | 2017-05-22 | CON-Z4-LS9-ELE-0150 SS | 69.8d | 0d | Electrician [720 h]; LC Crew [144 h] | 34,882 | 0 | 0 | 0.0084514848 | 6 | RPI - CONS | Z2 | LS12 | ELEC | 1.3.6.10 | CONS | CONS | ZONE-4 | LS-9 |
| CON-Z4-LS9-ELE-0180 |  | LV / MV Cable Dressing, termination of Transformer including grounding | 14.4d | 2017-05-06 | 2017-05-22 | CON-Z4-LS9-ELE-0080 SS | 31.4d | 0d | Electrician [720 h]; LC Crew [144 h] | 8,720.5 | 0 | 0 | 0.1137718198 | 6 | RPI - CONS | Z2 | LS12 | ELEC | 1.3.6.10 | CONS | CONS | ZONE-4 | LS-9 |
| CON-Z4-LS9-ELE-0090 |  | Installation of LV Panel Boards | 7.2d | 2017-05-09 | 2017-05-17 | CON-Z4-LS9-ELE-0080 SS, CON-Z4-LS9-ELE-0170 SS | 69.8d | 0d | Electrician [78 h]; LC Crew [52 h] | 129,018 | 0 | 0 | 0.0738239058 | 6 | RPI - CONS | Z2 | LS12 | ELEC | 1.3.6.10 | CONS | CONS | ZONE-4 | LS-9 |
| CON-Z4-LS9-ELE-0100 |  | Installation of Equipments including 13.8 kv Transformer (MCC, ATS, CP, DDCP, CB ..) | 16.8d | 2017-05-09 | 2017-05-28 | CON-Z4-LS9-ELE-0090 SS, CON-Z4-LS9-ELE-0180 SS, PR-Z4-CW-CW-173-0080 | 71.4d | 25.8d | Electrician [840 h]; LC Crew [168 h] | 30,342 | 0 | 0 | 0.0184559765 | 6 | RPI - CONS | Z2 | LS12 | ELEC | 1.3.6.10 | CONS | CONS | ZONE-4 | LS-9 |
| CON-Z4-LS9-ELE-0110 |  | Installation of Fire Alarm System including FACP, Detectors, Pull Station & Accessories | 16.8d | 2017-05-09 | 2017-05-28 | CON-Z4-LS9-ELE-0090 SS, PR-Z3-GE-GE-244-0080 | 71.4d | 0d | Electrician [840 h]; LC Crew [168 h] | 43,757.5 | 0 | 0 | 0.012921829 | 6 | RPI - CONS | Z2 | LS12 | ELEC | 1.3.6.10 | CONS | CONS | ZONE-4 | LS-9 |
| CON-Z4-LS9-ELE-0120 |  | Installation of Ultrasonic Level Sensor / Controller at LS-9 | 16.8d | 2017-05-09 | 2017-05-28 | CON-Z4-LS9-ELE-0110 SS | 71.4d | 25.8d | Electrician [840 h]; LC Crew [168 h] | 7,986.7 | 0 | 0 | 0.0128180201 | 6 | RPI - CONS | Z2 | LS12 | ELEC | 1.3.6.10 | CONS | CONS | ZONE-4 | LS-9 |
| CON-Z4-LS9-ELE-0170 |  | Installation of Grid Grounding, Equipment Grounding | 12d | 2017-05-09 | 2017-05-22 | CON-Z4-LS9-ELE-0160 SS+2.4d | 69.8d | 0d | Electrician [600 h]; LC Crew [120 h] | 8,720.5 | 0 | 0 | 0.0287130592 | 6 | RPI - CONS | Z2 | LS12 | ELEC | 1.3.6.10 | CONS | CONS | ZONE-4 | LS-9 |
| CON-Z4-LS9-ELE-0130 |  | Installation of Lighting Fixtures, Wiring Devices, Outlets, Disconnect Switches | 12d | 2017-05-16 | 2017-05-30 | PR-Z3-EW-EW-44-0080, CON-Z4-LS9-ELE-0090 SS+6.4d | 69.8d | 24.2d | Electrician [600 h]; LC Crew [120 h] | 3,993.35 | 0 | 0 | 0.0184559765 | 6 | RPI - CONS | Z2 | LS12 | ELEC | 1.3.6.10 | CONS | CONS | ZONE-4 | LS-9 |
| CON-Z4-LS9-ELE-0190 |  | Installation of Direct Buried Cable from Transformer to Circuit Breakers | 12d | 2017-05-23 | 2017-06-05 | CON-Z4-LS9-ELE-0180 | 31.4d | 0d | Electrician [78 h]; LC Crew [52 h] | 6,105.6 | 0 | 0 | 0.2730523675 | 6 | RPI - CONS | Z2 | LS12 | ELEC | 1.3.6.10 | CONS | CONS | ZONE-4 | LS-9 |
| CON-Z4-LS9-ELE-0200 |  | Installation of Lighting Poles (Remaining Works) | 12d | 2017-05-23 | 2017-06-05 | PR-Z4-CW-CW-169-0080, CON-Z4-LS9-ELE-0190 SS | 31.4d | 0d | Electrician [78 h]; LC Crew [52 h] | 6,056.55 | 0 | 0 | 0.0642154966 | 6 | RPI - CONS | Z2 | LS12 | ELEC | 1.3.6.10 | CONS | CONS | ZONE-4 | LS-9 |
|  | 7 | **External Works** |  | 2017-06-06 | 2017-08-03 |  |  |  |  |  |  |  |  |  |  |  |  |  |  |  |  |  |  |
| CON-Z4-LS9-EW-0010 |  | Cable Trench for Main feeder of LS # 9 to Transformer | 7.2d | 2017-06-06 | 2017-06-14 | CON-Z4-LS9-ELE-0080, CON-Z4-LS9-ELE-0200 | 31.4d | 0d | Electrician [78 h]; LC Crew [52 h] | 7,652 | 0 | 0 | 0.0161946141 | 6 | RPI - CONS | Z2 | LS12 | CIVIL | 1.3.6.10 | CONS | CONS | ZONE-4 | LS-9 |
| CON-Z4-LS9-EW-0020 |  | Installation of Pad Mounted Transformer for Power Supply of LS-9 | 7.2d | 2017-06-14 | 2017-06-22 | CON-Z4-LS9-EW-0010 | 31.4d | 0d | Mechanical Technician [26 h]; Common Labor / Helper [52 h]; Operator - Mobile Crane [26 h]; Driver - Flat Bed Trailer [26 h] | 7,652 | 0 | 0 | 0.0161946141 | 6 | RPI - CONS | Z2 | LS12 | CIVIL | 1.3.6.10 | CONS | CONS | ZONE-4 | LS-9 |
| CON-Z4-LS9-EW-0030 |  | Installation of concrete padestal for Emergency Generator | 8d | 2017-06-14 | 2017-06-24 | CON-Z4-LS9-EW-0020 SS | 31.4d | 0d | Steel Fixer [78 h]; Shuttering Carpenter [78 h]; Concrete Mason [78 h] | 4,214.88 | 0 | 0 | 0.0089203287 | 6 | RPI - CONS | Z2 | LS12 | CIVIL | 1.3.6.10 | CONS | CONS | ZONE-4 | LS-9 |
| CON-Z4-LS9-EW-0050 |  | Installation of Concrete Side Walks near electrical Room | 9.6d | 2017-06-14 | 2017-06-25 | CON-Z4-LS9-EW-0030 SS | 31.4d | 0d | Steel Fixer [78 h]; Shuttering Carpenter [78 h]; Concrete Mason [78 h]; Common Labor / Helper [52 h] | 5,000 | 0 | 0 | 0.0105819485 | 6 | RPI - CONS | Z2 | LS12 | CIVIL | 1.3.6.10 | CONS | CONS | ZONE-4 | LS-9 |
| CON-Z4-LS9-EW-0060 |  | Construction of Concrete Valve Box | 7.2d | 2017-06-14 | 2017-06-22 | CON-Z4-LS9-EW-0050 SS | 31.4d | 0d | Steel Fixer [78 h]; Shuttering Carpenter [78 h]; Concrete Mason [78 h]; Mechanical Technician [52 h] | 1,221.7 | 0 | 0 | 0.0025855933 | 6 | RPI - CONS | Z2 | LS12 | CIVIL | 1.3.6.10 | CONS | CONS | ZONE-4 | LS-9 |
| CON-Z4-LS9-EW-0070 |  | General Backfilling for LS-9 Area | 5.6d | 2017-06-19 | 2017-06-25 | CON-Z4-LS9-EW-0060 SS+4d | 31.4d | 0d | Common Labor / Helper [78 h]; Operator - Loader [26 h]; Driver - Dump Truck [26 h]; Operator - Bobcat [26 h]; Operator - Roller-Compactor (2~10 Ton) [26 h]; Operator - Roller (25 Ton) [26 h]; Driver - Water Tanker [26 h]; Loader [28 h]; Dump Truck [28 h]; Bobcat [28 h]; Roller-Compactor (2~10 Ton) [28 h]; Roller-Compactor (25 Ton) [28 h]; Water Tanker [28 h] | 71,446.93 | 0 | 0 | 0.1723734445 | 6 | RPI - CONS | Z2 | LS12 | CIVIL | 1.3.6.10 | CONS | CONS | ZONE-4 | LS-9 |
| CON-Z4-LS9-EW-0040 |  | Installation of Diesel Generator and Dummy Loads | 14.4d | 2017-06-24 | 2017-07-15 | CON-Z4-LS9-EW-0030 | 36.2d | 0d | Mechanical Technician [26 h]; Common Labor / Helper [52 h]; Operator - Mobile Crane [26 h]; Driver - Flat Bed Trailer [26 h]; Mobile Crane ( 25-60 Ton) [28 h]; Flat Bed Trailer [28 h] | 21,503 | 0 | 0 | 0.0455087279 | 6 | RPI - CONS | Z2 | LS12 | CIVIL | 1.3.6.10 | CONS | CONS | ZONE-4 | LS-9 |
| CON-Z4-LS9-EW-0080 |  | Installation of curb stone | 6.4d | 2017-06-25 | 2017-07-08 | CON-Z4-LS9-EW-0030 SS, CON-Z4-LS9-EW-0070 | 31.4d | 0d | Steel Fixer [78 h]; Shuttering Carpenter [78 h]; Concrete Mason [78 h]; Common Labor / Helper [52 h] | 13,825.56 | 0 | 0 | 0.0292602729 | 6 | RPI - CONS | Z2 | LS12 | CIVIL | 1.3.6.10 | CONS | CONS | ZONE-4 | LS-9 |
| CON-Z4-LS9-EW-0090 |  | Installation of Precast fence @ LS-9 | 14.4d | 2017-07-05 | 2017-07-22 | CON-Z4-LS9-EW-0080 SS+4.8d | 31.4d | 0d | Common Labor / Helper [78 h]; Fence Crew - Lift Station [78 h]; Operator - Mobile Crane [26 h] | 534,115.03 | 0 | 0 | 1.1635207345 | 6 | RPI - CONS | Z2 | LS12 | CIVIL | 1.3.6.10 | CONS | CONS | ZONE-4 | LS-9 |
| CON-Z4-LS9-EW-0100 |  | Installation of Steel Gate (Gate swing 4850 mm, small gate 1200mm) | 4d | 2017-07-19 | 2017-07-24 | CON-Z4-LS9-EW-0090 FF+1.6d | 31.4d | 0d | Common Labor / Helper [52 h]; Operator - Forklift [26 h]; Forklift [28 h] | 25,384.29 | 0 | 0 | 0.0537230501 | 6 | RPI - CONS | Z2 | LS12 | CIVIL | 1.3.6.10 | CONS | CONS | ZONE-4 | LS-9 |
| CON-Z4-LS9-EW-0110 |  | Asphalt pavement at Lift Station # 9 Area | 5.6d | 2017-07-24 | 2017-07-31 | CON-Z4-LS9-EW-0080, CON-Z4-LS9-EW-0070, CON-Z4-LS9-EW-0100, CON-Z4-LS9-EW-0090 | 31.4d | 0d | Common Labor / Helper [52 h]; Road Works Crew [52 h]; Operator - Asphalt Paver [26 h]; Operator - Asphalt Compactor / Roller [26 h]; Operator - Roller (25 Ton) [26 h] | 66,786.48 | 0 | 0 | 0.141346219 | 6 | RPI - CONS | Z2 | LS12 | CIVIL | 1.3.6.10 | CONS | CONS | ZONE-4 | LS-9 |
| CON-Z4-LS9-EW-0120 |  | Road Marking at Lift Station # 9 Area | 3.2d | 2017-07-31 | 2017-08-03 | CON-Z4-LS9-EW-0110 | 31.4d | 0d | Common Labor / Helper [104 h] | 1,357.45 | 0 | 0 | 0.0028728932 | 6 | RPI - CONS | Z2 | LS12 | CIVIL | 1.3.6.10 | CONS | CONS | ZONE-4 | LS-9 |
| CON-Z4-LS9-EW-0130 |  | Traffic Sign at Lift Station # 9 Area | 2.4d | 2017-07-31 | 2017-08-02 | CON-Z4-LS9-EW-0110, CON-Z4-LS9-EW-0120 SS | 31.4d | 0d | Shuttering Carpenter [26 h]; Common Labor / Helper [52 h] | 3,868.73 | 0 | 0 | 0.0081877404 | 6 | RPI - CONS | Z2 | LS12 | CIVIL | 1.3.6.10 | CONS | CONS | ZONE-4 | LS-9 |

Notes:
- CON-Z4-LS9-ELE-0010: Expenses: (New Expense Item) 17441
- CON-Z4-LS9-ELE-0020: Expenses: (New Expense Item) 31946.8
- CON-Z4-LS9-ELE-0050: Expenses: (New Expense Item) 52323
- CON-Z4-LS9-ELE-0030: Expenses: (New Expense Item) 6056.55
- CON-Z4-LS9-ELE-0040: Expenses: (New Expense Item) 34882
- CON-Z4-LS9-ELE-0060: Expenses: (New Expense Item) 3560
- CON-Z4-LS9-ELE-0070: Expenses: (New Expense Item) 17441
- CON-Z4-LS9-ELE-0080: Expenses: (New Expense Item) 31946.8
- CON-Z4-LS9-ELE-0140: Expenses: (New Expense Item) 3993.35
- CON-Z4-LS9-ELE-0150: Expenses: (New Expense Item) 13567
- CON-Z4-LS9-ELE-0160: Expenses: (New Expense Item) 34882
- CON-Z4-LS9-ELE-0180: Expenses: (New Expense Item) 8720.5
- CON-Z4-LS9-ELE-0090: Expenses: (New Expense Item) 129018
- CON-Z4-LS9-ELE-0100: Expenses: (New Expense Item) 30342
- CON-Z4-LS9-ELE-0110: Expenses: (New Expense Item) 43757.5
- CON-Z4-LS9-ELE-0120: Expenses: (New Expense Item) 7986.7
- CON-Z4-LS9-ELE-0170: Expenses: (New Expense Item) 8720.5
- CON-Z4-LS9-ELE-0130: Expenses: (New Expense Item) 3993.35
- CON-Z4-LS9-ELE-0190: Expenses: (New Expense Item) 6105.6
- CON-Z4-LS9-ELE-0200: Expenses: (New Expense Item) 6056.55
- CON-Z4-LS9-EW-0010: Expenses: (New Expense Item) 7652
- CON-Z4-LS9-EW-0020: Expenses: (New Expense Item) 7652
- CON-Z4-LS9-EW-0030: Expenses: (New Expense Item) 4214.88
- CON-Z4-LS9-EW-0050: Expenses: (New Expense Item) 5000
- CON-Z4-LS9-EW-0060: Expenses: (New Expense Item) 1221.7
- CON-Z4-LS9-EW-0070: Expenses: (New Expense Item) 71446.9
- CON-Z4-LS9-EW-0040: Expenses: (New Expense Item) 21503
- CON-Z4-LS9-EW-0080: Expenses: (New Expense Item) 13825.6
- CON-Z4-LS9-EW-0090: Expenses: (New Expense Item) 534115
- CON-Z4-LS9-EW-0100: Expenses: (New Expense Item) 25384.3
- CON-Z4-LS9-EW-0110: Expenses: (New Expense Item) 66786.5
- CON-Z4-LS9-EW-0120: Expenses: (New Expense Item) 1357.45
- CON-Z4-LS9-EW-0130: Expenses: (New Expense Item) 3868.73

| ID | WBS | Activity | Type | Duration | Start | Finish | Predecessors | Total float | Free float | Resources | Cost | Activity Wt% | Weight % | Cost Wt | RPI - PHASE | RPI - CONSTRUCTION | RPI - ZONES | RPI - BUILDINGS | RPI - TYPE OF WORK | RPI_P2 - BOQ ITEMS | RPI_P2 - CONSTRUCTION | RPI_P2 - PHASE | RPI_P2 - ZONES | RPI_P2 - BUILDINGS | RPI_P2 - DISCIPLINE / WORK TYPE | RPI_P2 - AREAS |
| --- | --- | --- | --- | --- | --- | --- | --- | --- | --- | --- | --- | --- | --- | --- | --- | --- | --- | --- | --- | --- | --- | --- | --- | --- | --- | --- |
|  | 8 | **Testing & Pre-Commissioning** |  |  | 2017-03-07 | 2017-08-02 |  |  |  |  |  |  |  |  |  |  |  |  |  |  |  |  |  |  |  |  |
| CON-Z4-LS9-TC-0010 |  | Hydro Testing - Plumbing Works - LS#9 |  | 9.6d | 2017-03-07 | 2017-03-18 | CON-Z4-LS9-ME-0050 | 145d | 113.6d | Plumber [26 h]; Common Labor / Helper [52 h]; Driver - Water Tanker [26 h] | 12,088.64 | 0 | 0 | 0.0085280982 | 6 | RPI - CONS | Z2 | LS12 | MECH | 1.3.6.10 | CONS | CONS | ZONE-4 | LS-9 |  |  |
| CON-Z4-LS9-TC-0020 |  | Testing & Balancing of HVAC System - LS#9 |  | 11.2d | 2017-07-01 | 2017-07-13 | CON-Z4-LS9-ME-0070 | 48.8d | 12.6d | Mechanical Technician [26 h]; HVAC Crew [26 h] | 24,177.27 | 0 | 0 | 0.0255842733 | 6 | RPI - CONS | Z2 | LS12 | MECH | 1.3.6.10 | CONS | CONS | ZONE-4 | LS-9 |  |  |
| CON-Z4-LS9-TC-0040 |  | Testing & Pre-commissioning of Electrical Works - LS#9 |  | 12.8d | 2017-07-02 | 2017-07-17 | CON-Z4-LS9-ELE-0060, CON-Z4-LS9-ELE-0100, CON-Z4-LS9-ELE-0120, CON-Z4-LS9-ME-0080, CON-Z4-LS9-ELE-0130, CON-Z4-LS9-ELE-0050 | 45.6d | 14.2d | Electrician [78 h]; LC Crew [52 h] | 4,029.55 | 0 | 0 | 0.0248538226 | 6 | RPI - CONS | Z2 | LS12 | ELEC | 1.3.6.10 | CONS | CONS | ZONE-4 | LS-9 |  |  |
| CON-Z4-LS9-TC-0030 |  | Testing & Pre-commissioning of Mechanical Works - LS#9 |  | 11.2d | 2017-07-15 | 2017-07-27 | CON-Z4-LS9-ME-0030, CON-Z4-LS9-TC-0020 SS, CON-Z4-LS9-ME-0080, CON-Z4-LS9-EW-0040 | 36.2d | 4.8d | Mechanical Technician [52 h]; Specialist Works Crew [26 h] | 11,743.5 | 0 | 0 | 0.0511685254 | 6 | RPI - CONS | Z2 | LS12 | MECH | 1.3.6.10 | CONS | CONS | ZONE-4 | LS-9 |  |  |
| CON-Z4-LS9-TC-0060 |  | Mechanical Completion of LS#9 | milestone | 0d | 2017-08-02 | 2017-08-02 | CON-Z4-LS9-TC-0020 FF, CON-Z4-LS9-TC-0040, CON-Z4-LS9-TC-0020, CON-Z4-LS9-EW-0130, CON-Z4-LS9-TC-0010, CON-Z4-LS9-TC-0030 | 31.4d | 1.2d |  |  | 0 | 0 | 0 | 6 | RPI - CONS | Z2 | LS12 | CIVIL | 1.3.6.10 | CONS | CONS | ZONE-4 | LS-9 |  |  |
|  | 5 | **LANDSCAPING FOR ZONE - 2 & ZONE - 3** |  |  | 2016-11-27 | 2017-11-01 |  |  |  |  |  |  |  |  |  |  |  |  |  |  |  |  |  |  |  |  |
|  | 5 | **LANDSCAPING WORKS** |  |  | 2016-11-27 | 2017-09-18 |  |  |  |  |  |  |  |  |  |  |  |  |  |  |  |  |  |  |  |  |
|  | 1 | **LANDSCAPING WORKS (Palm Trees for Existing and New Roads)** |  |  | 2016-11-27 | 2017-09-18 |  |  |  |  |  |  |  |  |  |  |  |  |  |  |  |  |  |  |  |  |
|  | 1 | **Replace dead Palm trees and dispose off site to Aramco's approval in Zone-2** |  |  | 2017-06-05 | 2017-07-03 |  |  |  |  |  |  |  |  |  |  |  |  |  |  |  |  |  |  |  |  |
| CON-Z2-LS-PT-0010 |  | Replace Dead Palm Trees and dispose off to designated Area in Zone-2 |  | 20d | 2017-06-05 | 2017-07-03 | PR-Z3-LW-LS-93-0080, CON-Z4-UTI-RD-PT-010, CON-Z4-UTI-RD-R3-010 SS | 57.2d | 0d | Common Labor / Helper [52 h]; Operator - Forklift [26 h]; Forklift [28 h] | 31,309.82 |  |  |  |  |  |  |  |  | 1.3.7.10 | CONS | CONS | ZONE-2 |  | SOFTSCAPE |  |
|  | 2 | **Replace dead Palm trees and dispose off site to Aramco's approval in Zone-3** |  |  | 2017-06-11 | 2017-08-03 |  |  |  |  |  |  |  |  |  |  |  |  |  |  |  |  |  |  |  |  |
| CON-Z3-LS-PT-0010 |  | Replace Dead Palm Trees and dispose off to designated Area in Zone-3 (Along Road 1,2,3,4,5) |  | 42d | 2017-06-11 | 2017-08-03 | CON-Z2-LS-PT-0010 SS+5d | 57.2d | 0d | Common Labor / Helper [52 h]; Operator - Forklift [26 h] | 1,296,226.7 |  |  |  |  |  |  |  |  | 1.3.7.20 | CONS | CONS | ZONE-3 |  | SOFTSCAPE |  |
|  | 3 | **Landscaping in Zone-3** |  |  | 2016-11-27 | 2017-09-18 |  |  |  |  |  |  |  |  |  |  |  |  |  |  |  |  |  |  |  |  |
|  | 1 | **Landscaping Works (Soft and Hard) including Street Lighting Work for Public Realms** |  |  | 2016-11-27 | 2017-09-18 |  |  |  |  |  |  |  |  |  |  |  |  |  |  |  |  |  |  |  |  |
| CON-Z3-SF-LS-GE-0010 |  | Start of Landscaping Works in Public Realms | milestone | 0d | 2016-11-27 | 2016-11-27 | CON-CON-CON-CON-0010 FS+90d | 168.6d | 0d |  |  |  |  |  |  |  |  |  |  | 1.3.7.30 | CONS | CONS | ZONE-3 |  | SOFTSCAPE | REALM |
| CON-Z3-SF-LS-GE-0020 |  | Finish of Landscaping Works in Public Realms | milestone | 0d | 2017-09-10 | 2017-09-10 | CON-Z3-LS-SAND-30, CON-Z3-LS-SAND-0010, CON-Z3-SL-LS-750 | 121.2d |  | Common Labor / Helper [52 h]; Finishing Work Crew [52 h] |  |  |  |  |  |  |  |  |  | 1.3.7.30 | CONS | CONS | ZONE-3 |  | SOFTSCAPE | REALM |
|  | 3 | **Soft Landscaping in Public Realms (Trees,Plants,Shurbs,Gravel Mulch,Sandfilling)** |  |  | 2017-07-16 | 2017-09-18 |  |  |  |  |  |  |  |  |  |  |  |  |  |  |  |  |  |  |  |  |
|  | 2 | **Soft Landscaping for Area-1 (Public Realms Between Road-A and Road-4)** |  |  | 2017-07-16 | 2017-09-06 |  |  |  |  |  |  |  |  |  |  |  |  |  |  |  |  |  |  |  |  |
|  | 1 | **Trees** |  |  | 2017-07-16 | 2017-07-30 |  |  |  |  |  |  |  |  |  |  |  |  |  |  |  |  |  |  |  |  |
| CON-Z3-LS-TR-0010 |  | Instalaltion of Washing Tonia Robusta |  | 4d | 2017-07-16 | 2017-07-20 | PR-Z3-LW-LS-94-0080, CON-Z3-HRD-LS-410 FS+24d | 114.8d | 0d | Soft Landscaping Crew [26 h] | 13,076.95 |  |  |  |  |  |  |  |  | 1.3.7.30 | CONS | CONS | ZONE-3 |  | SOFTSCAPE | REALM |
| CON-Z3-LS-TR-0020 |  | Instalaltion of Jacaranda |  | 4d | 2017-07-18 | 2017-07-23 | PR-Z3-LW-LS-95-0080, CON-Z3-LS-TR-0010 SS+1.6d | 124.4d | 0d | Soft Landscaping Crew [26 h] | 21,368.3 |  |  |  |  |  |  |  |  | 1.3.7.30 | CONS | CONS | ZONE-3 |  | SOFTSCAPE | REALM |
| CON-Z3-LS-TR-0030 |  | Instalaltion of Cassia Fistula |  | 4d | 2017-07-20 | 2017-07-24 | PR-Z3-LW-LS-96-0080, CON-Z3-LS-TR-0020 SS+1.6d | 124.4d | 0d | Soft Landscaping Crew [26 h] | 25,517.94 |  |  |  |  |  |  |  |  | 1.3.7.30 | CONS | CONS | ZONE-3 |  | SOFTSCAPE | REALM |
| CON-Z3-LS-TR-0040 |  | Instalaltion of Al Bizia Jublibrissin |  | 4d | 2017-07-22 | 2017-07-26 | CON-Z3-LS-TR-0030 SS+1.6d | 124.4d | 0d | Soft Landscaping Crew [26 h] | 32,298.88 |  |  |  |  |  |  |  |  | 1.3.7.30 | CONS | CONS | ZONE-3 |  | SOFTSCAPE | REALM |
| CON-Z3-LS-TR-0050 |  | Instalaltion of Chamarops Humilis |  | 4d | 2017-07-24 | 2017-07-29 | CON-Z3-LS-TR-0040 SS+1.6d | 124.4d | 0d | Soft Landscaping Crew [26 h] | 62,602.43 |  |  |  |  |  |  |  |  | 1.3.7.30 | CONS | CONS | ZONE-3 |  | SOFTSCAPE | REALM |
| CON-Z3-LS-TR-0060 |  | Instalaltion of Cycas Revolute |  | 4d | 2017-07-25 | 2017-07-30 | CON-Z3-LS-TR-0050 SS+1.6d | 124.4d | 0d | Soft Landscaping Crew [26 h] | 11,328.06 |  |  |  |  |  |  |  |  | 1.3.7.30 | CONS | CONS | ZONE-3 |  | SOFTSCAPE | REALM |

Notes:
- CON-Z4-LS9-TC-0010: Expenses: (New Expense Item) 12088.6
- CON-Z4-LS9-TC-0020: Expenses: (New Expense Item) 24177.3
- CON-Z4-LS9-TC-0040: Expenses: (New Expense Item) 4029.55
- CON-Z4-LS9-TC-0030: Expenses: (New Expense Item) 11743.5
- CON-Z2-LS-PT-0010: Expenses: (New Expense Item) 31309.8
- CON-Z3-LS-PT-0010: Expenses: (New Expense Item) 1296227
- CON-Z3-LS-TR-0010: Expenses: (New Expense Item) 13077
- CON-Z3-LS-TR-0020: Expenses: (New Expense Item) 21368.3
- CON-Z3-LS-TR-0030: Expenses: (New Expense Item) 25517.9
- CON-Z3-LS-TR-0040: Expenses: (New Expense Item) 32298.9
- CON-Z3-LS-TR-0050: Expenses: (New Expense Item) 62602.4
- CON-Z3-LS-TR-0060: Expenses: (New Expense Item) 11328.1

| ID | WBS | Activity | Duration | Start | Finish | Predecessors | Total float | Free float | Resources | Cost | RPI_P2 - BOQ ITEMS | RPI_P2 - CONSTRUCTION | RPI_P2 - PHASE | RPI_P2 - ZONES | RPI_P2 - AREAS | RPI_P2 - DISCIPLINE / WORK TYPE |
| --- | --- | --- | --- | --- | --- | --- | --- | --- | --- | --- | --- | --- | --- | --- | --- | --- |
|  | 2 | **Shurbs** |  | 2017-07-27 | 2017-08-07 |  |  |  |  |  |  |  |  |  |  |  |
| CON-Z3-LS-SH-0040 |  | Installation of bougainvilea SP | 3.2d | 2017-07-27 | 2017-07-31 | CON-Z3-LS-TR-0060 SS+1.6d | 124.4d | 0d | Soft Landscaping Crew [26 h] | 24,928.88 | 1.3.7.30 | CONS | CONS | ZONE-3 | REALM | SOFTSCAPE |
| CON-Z3-LS-SH-0050 |  | Installation of Caesalpinia Pulchrrima | 3.2d | 2017-07-30 | 2017-08-02 | CON-Z3-LS-SH-0040 SS+1.6d | 124.4d | 0d | Soft Landscaping Crew [26 h] | 24,928.88 | 1.3.7.30 | CONS | CONS | ZONE-3 | REALM | SOFTSCAPE |
| CON-Z3-LS-SH-0060 |  | Installation of Tecoma Stans | 3.2d | 2017-07-31 | 2017-08-03 | CON-Z3-LS-SH-0050 SS+1.6d | 124.4d | 0d | Soft Landscaping Crew [26 h] | 24,928.88 | 1.3.7.30 | CONS | CONS | ZONE-3 | REALM | SOFTSCAPE |
| CON-Z3-LS-SH-0070 |  | Instalaltion of City Krzyzes | 3.2d | 2017-08-02 | 2017-08-06 | CON-Z3-LS-SH-0060 SS+1.6d | 124.4d | 0d | Soft Landscaping Crew [26 h] | 24,928.88 | 1.3.7.30 | CONS | CONS | ZONE-3 | REALM | SOFTSCAPE |
| CON-Z3-LS-SH-0080 |  | Installation of Hibiscus Roas-Sinensis | 3.2d | 2017-08-03 | 2017-08-07 | CON-Z3-LS-SH-0070 SS+1.6d | 124.4d | 0d | Soft Landscaping Crew [26 h] | 24,928.88 | 1.3.7.30 | CONS | CONS | ZONE-3 | REALM | SOFTSCAPE |
|  | 3 | **Ground Covers** |  | 2017-08-06 | 2017-09-06 |  |  |  |  |  |  |  |  |  |  |  |
|  | 1 | **Plants** |  | 2017-08-06 | 2017-08-21 |  |  |  |  |  |  |  |  |  |  |  |
| CON-Z3-LS-PL-0010 |  | Installation of Agva | 3.2d | 2017-08-06 | 2017-08-09 | CON-Z3-LS-SH-0080 SS+1.6d | 124.4d | 0d | Soft Landscaping Crew [26 h] | 13,087.66 | 1.3.7.30 | CONS | CONS | ZONE-3 | REALM | SOFTSCAPE |
| CON-Z3-LS-PL-0020 |  | Installation of Aloe Vera | 3.2d | 2017-08-08 | 2017-08-12 | CON-Z3-LS-PL-0010 SS+1.6d | 124.4d | 0d | Soft Landscaping Crew [26 h] | 13,087.66 | 1.3.7.30 | CONS | CONS | ZONE-3 | REALM | SOFTSCAPE |
| CON-Z3-LS-PL-0030 |  | Installation of Cenchrus Ciliaris | 3.2d | 2017-08-09 | 2017-08-13 | CON-Z3-LS-PL-0020 SS+1.6d | 124.4d | 0d | Soft Landscaping Crew [26 h] | 13,087.66 | 1.3.7.30 | CONS | CONS | ZONE-3 | REALM | SOFTSCAPE |
| CON-Z3-LS-PL-0040 |  | Installation of Pennisetum Setaceum | 3.2d | 2017-08-12 | 2017-08-15 | CON-Z3-LS-PL-0030 SS+1.6d | 124.4d | 0d | Soft Landscaping Crew [26 h] | 13,087.66 | 1.3.7.30 | CONS | CONS | ZONE-3 | REALM | SOFTSCAPE |
| CON-Z3-LS-PL-0050 |  | Instalaltion of Cytsdon Dactylon | 3.2d | 2017-08-13 | 2017-08-16 | CON-Z3-LS-PL-0040 SS+1.6d | 124.4d | 0d | Soft Landscaping Crew [26 h] | 13,087.66 | 1.3.7.30 | CONS | CONS | ZONE-3 | REALM | SOFTSCAPE |
| CON-Z3-LS-PL-0060 |  | Installation of Carissa Grandiflora | 3.2d | 2017-08-15 | 2017-08-19 | CON-Z3-LS-PL-0050 SS+1.6d | 124.4d | 0d | Soft Landscaping Crew [26 h] | 13,087.66 | 1.3.7.30 | CONS | CONS | ZONE-3 | REALM | SOFTSCAPE |
| CON-Z3-LS-PL-0070 |  | Instalaltion of Wedelia Trilobata | 3.2d | 2017-08-17 | 2017-08-21 | CON-Z3-LS-PL-0060 SS+1.6d | 124.4d | 0d | Soft Landscaping Crew [26 h] | 8,725.11 | 1.3.7.30 | CONS | CONS | ZONE-3 | REALM | SOFTSCAPE |
|  | 2 | **Gravel Mulch Paving & Natural Stone Boulders** |  | 2017-08-19 | 2017-08-26 |  |  |  |  |  |  |  |  |  |  |  |
| CON-Z3-LS-GRAV-0010 |  | Instalaltion of Gravel Mulch and Natural Stone Boulders | 6.4d | 2017-08-19 | 2017-08-26 | PR-Z3-LW-LS-106-0080, CON-Z3-LS-PL-0070 SS+1.6d | 124.4d | 0d | Soft Landscaping Crew [26 h] | 12,464.44 | 1.3.7.30 | CONS | CONS | ZONE-3 | REALM | SOFTSCAPE |
|  | 3 | **Grass** |  | 2017-08-21 | 2017-08-30 |  |  |  |  |  |  |  |  |  |  |  |
| CON-Z3-LS-GRAS-0010 |  | Instalaltion of Grass | 8d | 2017-08-21 | 2017-08-30 | PR-Z3-LW-LS-116-0080, CON-Z3-LS-GRAV-0010 SS+1.6d | 124.4d | 0d | Soft Landscaping Crew [26 h] | 12,464.44 | 1.3.7.30 | CONS | CONS | ZONE-3 | REALM | SOFTSCAPE |
|  | 4 | **Sand Fill / Play Ground Sand** |  | 2017-08-23 | 2017-09-06 |  |  |  |  |  |  |  |  |  |  |  |
| CON-Z3-LS-SAND-0010 |  | Laying of Sandfilling 10mm thich and Playground Sand | 8d | 2017-08-23 | 2017-09-06 | PR-Z3-LW-LS-108-170, PR-Z3-LW-LS-103-0080, CON-Z3-LS-GRAS-0010 SS+2.4d | 124.4d | 3.2d | Common Labor / Helper [78 h]; Operator - Bobcat [26 h]; Driver - Water Tanker [26 h]; Operator - JCB [26 h]; Bobcat [28 h]; Water Tanker [28 h]; JCB [28 h] | 12,464.44 | 1.3.7.30 | CONS | CONS | ZONE-3 | REALM | SOFTSCAPE |
|  | 4 | **Soft Landscaping for Area-2 (Public Realms Between Road-4 and Road-B)** |  | 2017-07-20 | 2017-09-17 |  |  |  |  |  |  |  |  |  |  |  |
|  | 1 | **Trees** |  | 2017-07-20 | 2017-08-03 |  |  |  |  |  |  |  |  |  |  |  |
| CON-Z3-LS-TR-60 |  | Instalaltion of Washing Tonia Robusta | 4d | 2017-07-20 | 2017-07-25 | CON-Z3-LS-TR-0010 SS+4d, PR-Z3-LW-LS-94-0080 | 114.8d | 0d | Soft Landscaping Crew [26 h] | 25,517.94 | 1.3.7.30 | CONS | CONS | ZONE-3 | REALM | SOFTSCAPE |
| CON-Z3-LS-TR-70 |  | Instalaltion of Jacaranda | 4d | 2017-07-23 | 2017-07-27 | CON-Z3-LS-TR-60 SS+1.6d, PR-Z3-LW-LS-95-0080 | 115.6d | 0d | Soft Landscaping Crew [26 h] | 32,298.88 | 1.3.7.30 | CONS | CONS | ZONE-3 | REALM | SOFTSCAPE |
| CON-Z3-LS-TR-80 |  | Instalaltion of Cassia Fistula | 4d | 2017-07-25 | 2017-07-29 | PR-Z3-LW-LS-96-0080, CON-Z3-LS-TR-70 SS+1.6d | 115.6d | 0d | Soft Landscaping Crew [26 h] | 62,602.43 | 1.3.7.30 | CONS | CONS | ZONE-3 | REALM | SOFTSCAPE |
| CON-Z3-LS-TR-90 |  | Instalaltion of Al Bizia Jublibrissin | 4d | 2017-07-26 | 2017-07-31 | CON-Z3-LS-TR-80 SS+1.6d | 115.6d | 0d | Soft Landscaping Crew [26 h] | 11,328.06 | 1.3.7.30 | CONS | CONS | ZONE-3 | REALM | SOFTSCAPE |
| CON-Z3-LS-TR-100 |  | Instalaltion of Chamarops Humilis | 4d | 2017-07-29 | 2017-08-02 | CON-Z3-LS-TR-90 SS+1.6d | 115.6d | 0d | Soft Landscaping Crew [26 h] | 13,076.95 | 1.3.7.30 | CONS | CONS | ZONE-3 | REALM | SOFTSCAPE |
| CON-Z3-LS-TR-110 |  | Instalaltion of Cycas Revolute | 4d | 2017-07-30 | 2017-08-03 | CON-Z3-LS-TR-100 SS+1.6d | 115.6d | 0d | Soft Landscaping Crew [26 h] | 21,368.3 | 1.3.7.30 | CONS | CONS | ZONE-3 | REALM | SOFTSCAPE |

Notes:
- CON-Z3-LS-SH-0040: Expenses: (New Expense Item) 24928.9
- CON-Z3-LS-SH-0050: Expenses: (New Expense Item) 24928.9
- CON-Z3-LS-SH-0060: Expenses: (New Expense Item) 24928.9
- CON-Z3-LS-SH-0070: Expenses: (New Expense Item) 24928.9
- CON-Z3-LS-SH-0080: Expenses: (New Expense Item) 24928.9
- CON-Z3-LS-PL-0010: Expenses: (New Expense Item) 13087.7
- CON-Z3-LS-PL-0020: Expenses: (New Expense Item) 13087.7
- CON-Z3-LS-PL-0030: Expenses: (New Expense Item) 13087.7
- CON-Z3-LS-PL-0040: Expenses: (New Expense Item) 13087.7
- CON-Z3-LS-PL-0050: Expenses: (New Expense Item) 13087.7
- CON-Z3-LS-PL-0060: Expenses: (New Expense Item) 13087.7
- CON-Z3-LS-PL-0070: Expenses: (New Expense Item) 8725.11
- CON-Z3-LS-GRAV-0010: Expenses: (New Expense Item) 12464.4
- CON-Z3-LS-GRAS-0010: Expenses: (New Expense Item) 12464.4
- CON-Z3-LS-SAND-0010: Expenses: (New Expense Item) 12464.4
- CON-Z3-LS-TR-60: Expenses: (New Expense Item) 25517.9
- CON-Z3-LS-TR-70: Expenses: (New Expense Item) 32298.9
- CON-Z3-LS-TR-80: Expenses: (New Expense Item) 62602.4
- CON-Z3-LS-TR-90: Expenses: (New Expense Item) 11328.1
- CON-Z3-LS-TR-100: Expenses: (New Expense Item) 13077
- CON-Z3-LS-TR-110: Expenses: (New Expense Item) 21368.3

| ID | WBS | Activity | Duration | Start | Finish | Predecessors | Total float | Free float | Resources | Cost | RPI_P2 - BOQ ITEMS | RPI_P2 - CONSTRUCTION | RPI_P2 - PHASE | RPI_P2 - ZONES | RPI_P2 - AREAS | RPI_P2 - DISCIPLINE / WORK TYPE |
| --- | --- | --- | --- | --- | --- | --- | --- | --- | --- | --- | --- | --- | --- | --- | --- | --- |
|  | 2 | **Shurbs** |  | 2017-08-01 | 2017-08-12 |  |  |  |  |  |  |  |  |  |  |  |
| CON-Z3-LS-SH-80 |  | Installation of bougainvilea SP | 3.2d | 2017-08-01 | 2017-08-05 | CON-Z3-LS-TR-110 SS+1.6d | 115.6d | 0d | Soft Landscaping Crew [26 h] | 24,928.88 | 1.3.7.30 | CONS | CONS | ZONE-3 | REALM | SOFTSCAPE |
| CON-Z3-LS-SH-90 |  | Installation of Caesalpinia Pulchrrima | 3.2d | 2017-08-03 | 2017-08-07 | CON-Z3-LS-SH-80 SS+1.6d | 115.6d | 0d | Soft Landscaping Crew [26 h] | 24,928.88 | 1.3.7.30 | CONS | CONS | ZONE-3 | REALM | SOFTSCAPE |
| CON-Z3-LS-SH-100 |  | Installation of Tecoma Stans | 3.2d | 2017-08-05 | 2017-08-08 | CON-Z3-LS-SH-90 SS+1.6d | 115.6d | 0d | Soft Landscaping Crew [26 h] | 24,928.88 | 1.3.7.30 | CONS | CONS | ZONE-3 | REALM | SOFTSCAPE |
| CON-Z3-LS-SH-110 |  | Instalaltion of City Krzyzes | 3.2d | 2017-08-07 | 2017-08-10 | CON-Z3-LS-SH-100 SS+1.6d | 115.6d | 0d | Soft Landscaping Crew [26 h] | 24,928.88 | 1.3.7.30 | CONS | CONS | ZONE-3 | REALM | SOFTSCAPE |
| CON-Z3-LS-SH-120 |  | Installation of Hibiscus Roas-Sinensis | 3.2d | 2017-08-08 | 2017-08-12 | CON-Z3-LS-SH-110 SS+1.6d | 115.6d | 0d | Soft Landscaping Crew [26 h] | 24,928.88 | 1.3.7.30 | CONS | CONS | ZONE-3 | REALM | SOFTSCAPE |
|  | 3 | **Ground Covers** |  | 2017-08-10 | 2017-09-17 |  |  |  |  |  |  |  |  |  |  |  |
|  | 1 | **Plants** |  | 2017-08-10 | 2017-08-26 |  |  |  |  |  |  |  |  |  |  |  |
| CON-Z3-LS-PL-70 |  | Installation of Agva | 3.2d | 2017-08-10 | 2017-08-14 | CON-Z3-LS-SH-120 SS+1.6d | 115.6d | 0d | Soft Landscaping Crew [26 h] | 13,087.66 | 1.3.7.30 | CONS | CONS | ZONE-3 | REALM | SOFTSCAPE |
| CON-Z3-LS-PL-80 |  | Installation of Aloe Vera | 3.2d | 2017-08-13 | 2017-08-16 | CON-Z3-LS-PL-70 SS+1.6d | 115.6d | 0d | Soft Landscaping Crew [26 h] | 13,087.66 | 1.3.7.30 | CONS | CONS | ZONE-3 | REALM | SOFTSCAPE |
| CON-Z3-LS-PL-90 |  | Installation of Cenchrus Ciliaris | 3.2d | 2017-08-14 | 2017-08-17 | CON-Z3-LS-PL-80 SS+1.6d | 115.6d | 0d | Soft Landscaping Crew [26 h] | 8,725.11 | 1.3.7.30 | CONS | CONS | ZONE-3 | REALM | SOFTSCAPE |
| CON-Z3-LS-PL-100 |  | Installation of Pennisetum Setaceum | 3.2d | 2017-08-16 | 2017-08-20 | CON-Z3-LS-PL-90 SS+1.6d | 115.6d | 0d | Soft Landscaping Crew [26 h] | 13,087.66 | 1.3.7.30 | CONS | CONS | ZONE-3 | REALM | SOFTSCAPE |
| CON-Z3-LS-PL-110 |  | Instalaltion of Cytsdon Dactylon | 3.2d | 2017-08-17 | 2017-08-21 | CON-Z3-LS-PL-100 SS+1.6d | 115.6d | 0d | Soft Landscaping Crew [26 h] | 13,087.66 | 1.3.7.30 | CONS | CONS | ZONE-3 | REALM | SOFTSCAPE |
| CON-Z3-LS-PL-120 |  | Installation of Carissa Grandiflora | 3.2d | 2017-08-20 | 2017-08-23 | CON-Z3-LS-PL-110 SS+1.6d | 115.6d | 0d | Soft Landscaping Crew [26 h] | 13,087.66 | 1.3.7.30 | CONS | CONS | ZONE-3 | REALM | SOFTSCAPE |
| CON-Z3-LS-PL-130 |  | Instalaltion of Wedelia Trilobata | 3.2d | 2017-08-22 | 2017-08-26 | CON-Z3-LS-PL-120 SS+1.6d | 115.6d | 0d | Soft Landscaping Crew [26 h] | 13,087.66 | 1.3.7.30 | CONS | CONS | ZONE-3 | REALM | SOFTSCAPE |
|  | 2 | **Gravel Mulch Paving & Natural Stone Boulders** |  | 2017-08-23 | 2017-08-30 |  |  |  |  |  |  |  |  |  |  |  |
| CON-Z3-LS-GRAV-10 |  | Instalaltion of Gravel Mulch and Natural Stone Boulders | 6.4d | 2017-08-23 | 2017-08-30 | CON-Z3-LS-PL-130 SS+1.6d | 115.6d | 0d | Soft Landscaping Crew [26 h] | 12,464.44 | 1.3.7.30 | CONS | CONS | ZONE-3 | REALM | SOFTSCAPE |
|  | 3 | **Grass** |  | 2017-08-26 | 2017-09-09 |  |  |  |  |  |  |  |  |  |  |  |
| CON-Z3-LS-GRAS-10 |  | Instalaltion of Grass | 8d | 2017-08-26 | 2017-09-09 | CON-Z3-LS-GRAV-10 SS+1.6d | 115.6d | 0d | Soft Landscaping Crew [26 h] | 12,464.44 | 1.3.7.30 | CONS | CONS | ZONE-3 | REALM | SOFTSCAPE |
|  | 4 | **Sand Fill / Play Ground Sand** |  | 2017-09-07 | 2017-09-17 |  |  |  |  |  |  |  |  |  |  |  |
| CON-Z3-LS-SAND-10 |  | Laying of Sandfilling 10mm thich and Playground Sand | 8d | 2017-09-07 | 2017-09-17 | PR-Z3-LW-LS-103-0080, CON-Z3-LS-GRAS-10 SS+7.2d, CON-Z3-LS-SAND-0010 SS | 115.6d | 0.8d | Common Labor / Helper [520 h]; Operator - Bobcat [104 h]; Driver - Water Tanker [104 h]; Operator - JCB [104 h]; Bobcat [112 h]; Water Tanker [112 h]; JCB [112 h] | 12,464.44 | 1.3.7.30 | CONS | CONS | ZONE-3 | REALM | SOFTSCAPE |
|  | 1 | **Soft Landscaping for Area-3 (Public Realms Between Road-B and Road-A)** |  | 2017-07-25 | 2017-09-18 |  |  |  |  |  |  |  |  |  |  |  |
|  | 1 | **Trees** |  | 2017-07-25 | 2017-08-08 |  |  |  |  |  |  |  |  |  |  |  |
| CON-Z3-LS-TR-120 |  | Instalaltion of Washing Tonia Robusta | 4d | 2017-07-25 | 2017-07-30 | CON-Z3-LS-TR-60 SS+4d, CON-Z3-HRD-LS-430 SS | 114.8d | 0d | Soft Landscaping Crew [26 h] | 13,076.95 | 1.3.7.30 | CONS | CONS | ZONE-3 | REALM | SOFTSCAPE |
| CON-Z3-LS-TR-130 |  | Instalaltion of Jacaranda | 4d | 2017-07-27 | 2017-08-01 | CON-Z3-LS-TR-120 SS+1.6d | 114.8d | 0d | Soft Landscaping Crew [26 h] | 21,368.3 | 1.3.7.30 | CONS | CONS | ZONE-3 | REALM | SOFTSCAPE |
| CON-Z3-LS-TR-140 |  | Instalaltion of Cassia Fistula | 4d | 2017-07-30 | 2017-08-02 | CON-Z3-LS-TR-130 SS+1.6d | 114.8d | 0d | Soft Landscaping Crew [26 h] | 25,517.94 | 1.3.7.30 | CONS | CONS | ZONE-3 | REALM | SOFTSCAPE |
| CON-Z3-LS-TR-150 |  | Instalaltion of Al Bizia Jublibrissin | 4d | 2017-07-31 | 2017-08-05 | CON-Z3-LS-TR-140 SS+1.6d | 114.8d | 0d | Soft Landscaping Crew [26 h] | 32,298.88 | 1.3.7.30 | CONS | CONS | ZONE-3 | REALM | SOFTSCAPE |
| CON-Z3-LS-TR-160 |  | Instalaltion of Chamarops Humilis | 4d | 2017-08-02 | 2017-08-07 | CON-Z3-LS-TR-150 SS+1.6d | 114.8d | 0d | Soft Landscaping Crew [26 h] | 62,602.43 | 1.3.7.30 | CONS | CONS | ZONE-3 | REALM | SOFTSCAPE |
| CON-Z3-LS-TR-170 |  | Instalaltion of Cycas Revolute | 4d | 2017-08-03 | 2017-08-08 | CON-Z3-LS-TR-160 SS+1.6d | 114.8d | 0d | Soft Landscaping Crew [26 h] | 11,328.06 | 1.3.7.30 | CONS | CONS | ZONE-3 | REALM | SOFTSCAPE |

Notes:
- CON-Z3-LS-SH-80: Expenses: (New Expense Item) 24928.9
- CON-Z3-LS-SH-90: Expenses: (New Expense Item) 24928.9
- CON-Z3-LS-SH-100: Expenses: (New Expense Item) 24928.9
- CON-Z3-LS-SH-110: Expenses: (New Expense Item) 24928.9
- CON-Z3-LS-SH-120: Expenses: (New Expense Item) 24928.9
- CON-Z3-LS-PL-70: Expenses: (New Expense Item) 13087.7
- CON-Z3-LS-PL-80: Expenses: (New Expense Item) 13087.7
- CON-Z3-LS-PL-90: Expenses: (New Expense Item) 8725.11
- CON-Z3-LS-PL-100: Expenses: (New Expense Item) 13087.7
- CON-Z3-LS-PL-110: Expenses: (New Expense Item) 13087.7
- CON-Z3-LS-PL-120: Expenses: (New Expense Item) 13087.7
- CON-Z3-LS-PL-130: Expenses: (New Expense Item) 13087.7
- CON-Z3-LS-GRAV-10: Expenses: (New Expense Item) 12464.4
- CON-Z3-LS-GRAS-10: Expenses: (New Expense Item) 12464.4
- CON-Z3-LS-SAND-10: Expenses: (New Expense Item) 12464.4
- CON-Z3-LS-TR-120: Expenses: (New Expense Item) 13077
- CON-Z3-LS-TR-130: Expenses: (New Expense Item) 21368.3
- CON-Z3-LS-TR-140: Expenses: (New Expense Item) 25517.9
- CON-Z3-LS-TR-150: Expenses: (New Expense Item) 32298.9
- CON-Z3-LS-TR-160: Expenses: (New Expense Item) 62602.4
- CON-Z3-LS-TR-170: Expenses: (New Expense Item) 11328.1

| ID | WBS | Activity | Duration | Start | Finish | Predecessors | Total float | Free float | Resources | Cost | RPI_P2 - BOQ ITEMS | RPI_P2 - CONSTRUCTION | RPI_P2 - PHASE | RPI_P2 - ZONES | RPI_P2 - AREAS | RPI_P2 - DISCIPLINE / WORK TYPE |
| --- | --- | --- | --- | --- | --- | --- | --- | --- | --- | --- | --- | --- | --- | --- | --- | --- |
|  | 2 | **Shurbs** |  | 2017-08-08 | 2017-08-20 |  |  |  |  |  |  |  |  |  |  |  |
| CON-Z3-LS-SH-130 |  | Installation of bougainvilea SP | 3.2d | 2017-08-08 | 2017-08-12 | CON-Z3-LS-TR-170 | 114.8d | 0d | Soft Landscaping Crew [26 h] | 24,928.88 | 1.3.7.30 | CONS | CONS | ZONE-3 | REALM | SOFTSCAPE |
| CON-Z3-LS-SH-140 |  | Installation of Caesalpinia Pulchrrima | 3.2d | 2017-08-10 | 2017-08-14 | CON-Z3-LS-SH-130 SS+1.6d | 114.8d | 0d | Soft Landscaping Crew [26 h] | 24,928.88 | 1.3.7.30 | CONS | CONS | ZONE-3 | REALM | SOFTSCAPE |
| CON-Z3-LS-SH-150 |  | Installation of Tecoma Stans | 3.2d | 2017-08-13 | 2017-08-16 | CON-Z3-LS-SH-140 SS+1.6d | 114.8d | 0d | Soft Landscaping Crew [26 h] | 24,928.88 | 1.3.7.30 | CONS | CONS | ZONE-3 | REALM | SOFTSCAPE |
| CON-Z3-LS-SH-160 |  | Instalaltion of City Krzyzes | 3.2d | 2017-08-14 | 2017-08-17 | CON-Z3-LS-SH-150 SS+1.6d | 114.8d | 0d | Soft Landscaping Crew [26 h] | 24,928.88 | 1.3.7.30 | CONS | CONS | ZONE-3 | REALM | SOFTSCAPE |
| CON-Z3-LS-SH-170 |  | Installation of Hibiscus Roas-Sinensis | 3.2d | 2017-08-16 | 2017-08-20 | CON-Z3-LS-SH-160 SS+1.6d | 114.8d | 0d | Soft Landscaping Crew [26 h] | 24,928.88 | 1.3.7.30 | CONS | CONS | ZONE-3 | REALM | SOFTSCAPE |
|  | 3 | **Ground Covers** |  | 2017-08-17 | 2017-09-18 |  |  |  |  |  |  |  |  |  |  |  |
|  | 1 | **Plants** |  | 2017-08-17 | 2017-09-06 |  |  |  |  |  |  |  |  |  |  |  |
| CON-Z3-LS-PL-140 |  | Installation of Agva | 3.2d | 2017-08-17 | 2017-08-21 | CON-Z3-LS-SH-170 SS+1.6d | 114.8d | 0d | Soft Landscaping Crew [26 h] | 13,087.66 | 1.3.7.30 | CONS | CONS | ZONE-3 | REALM | SOFTSCAPE |
| CON-Z3-LS-PL-150 |  | Installation of Aloe Vera | 3.2d | 2017-08-20 | 2017-08-23 | CON-Z3-LS-PL-140 SS+1.6d | 114.8d | 0d | Soft Landscaping Crew [26 h] | 13,087.66 | 1.3.7.30 | CONS | CONS | ZONE-3 | REALM | SOFTSCAPE |
| CON-Z3-LS-PL-160 |  | Installation of Cenchrus Ciliaris | 3.2d | 2017-08-22 | 2017-08-26 | CON-Z3-LS-PL-150 SS+1.6d | 114.8d | 0d | Soft Landscaping Crew [26 h] | 13,087.66 | 1.3.7.30 | CONS | CONS | ZONE-3 | REALM | SOFTSCAPE |
| CON-Z3-LS-PL-170 |  | Installation of Pennisetum Setaceum | 3.2d | 2017-08-23 | 2017-08-27 | CON-Z3-LS-PL-160 SS+1.6d | 114.8d | 0d | Soft Landscaping Crew [26 h] | 13,087.66 | 1.3.7.30 | CONS | CONS | ZONE-3 | REALM | SOFTSCAPE |
| CON-Z3-LS-PL-180 |  | Instalaltion of Cytsdon Dactylon | 3.2d | 2017-08-26 | 2017-08-29 | CON-Z3-LS-PL-170 SS+1.6d | 114.8d | 0d | Soft Landscaping Crew [26 h] | 13,087.66 | 1.3.7.30 | CONS | CONS | ZONE-3 | REALM | SOFTSCAPE |
| CON-Z3-LS-PL-190 |  | Installation of Carissa Grandiflora | 3.2d | 2017-08-27 | 2017-08-30 | CON-Z3-LS-PL-180 SS+1.6d | 114.8d | 0d | Soft Landscaping Crew [26 h] | 13,087.66 | 1.3.7.30 | CONS | CONS | ZONE-3 | REALM | SOFTSCAPE |
| CON-Z3-LS-PL-200 |  | Instalaltion of Wedelia Trilobata | 3.2d | 2017-08-29 | 2017-09-06 | CON-Z3-LS-PL-190 SS+1.6d | 114.8d | 0d | Soft Landscaping Crew [26 h] | 8,725.11 | 1.3.7.30 | CONS | CONS | ZONE-3 | REALM | SOFTSCAPE |
|  | 2 | **Gravel Mulch Paving & Natural Stone Boulders** |  | 2017-09-05 | 2017-09-12 |  |  |  |  |  |  |  |  |  |  |  |
| CON-Z3-LS-GRAV-20 |  | Instalaltion of Gravel Mulch and Natural Stone Boulders | 6.4d | 2017-09-05 | 2017-09-12 | CON-Z3-LS-PL-200 SS+1.6d | 114.8d | 0d | Soft Landscaping Crew [26 h] | 12,464.44 | 1.3.7.30 | CONS | CONS | ZONE-3 | REALM | SOFTSCAPE |
|  | 3 | **Grass** |  | 2017-09-06 | 2017-09-16 |  |  |  |  |  |  |  |  |  |  |  |
| CON-Z3-LS-GRAS-20 |  | Instalaltion of Grass | 8d | 2017-09-06 | 2017-09-16 | CON-Z3-LS-GRAV-20 SS+1.6d | 114.8d | 0d | Soft Landscaping Crew [208 h] | 12,464.44 | 1.3.7.30 | CONS | CONS | ZONE-3 | REALM | SOFTSCAPE |
|  | 4 | **Sand Fill / Play Ground Sand** |  | 2017-09-09 | 2017-09-18 |  |  |  |  |  |  |  |  |  |  |  |
| CON-Z3-LS-SAND-20 |  | Laying of Sandfilling 10mm thich and Playground Sand | 8d | 2017-09-09 | 2017-09-18 | CON-Z3-LS-SAND-10 SS, CON-Z3-LS-GRAS-20 SS+1.6d | 114.8d | 1.6d | Common Labor / Helper [312 h]; Operator - Bobcat [104 h]; Driver - Water Tanker [104 h]; Operator - JCB [104 h]; Bobcat [112 h]; Water Tanker [112 h]; JCB [112 h] | 12,464.44 | 1.3.7.30 | CONS | CONS | ZONE-3 | REALM | SOFTSCAPE |
|  | 3 | **Soft Landscaping for Area-4 (Public Realms Between Road-A and Road-5)** |  | 2017-07-30 | 2017-09-14 |  |  |  |  |  |  |  |  |  |  |  |
|  | 1 | **Trees** |  | 2017-07-30 | 2017-09-14 |  |  |  |  |  |  |  |  |  |  |  |
| CON-Z3-LS-TR-180 |  | Instalaltion of Washing Tonia Robusta | 2.4d | 2017-07-30 | 2017-08-02 | CON-Z3-LS-TR-120 SS+4d | 117.2d | 0d | Soft Landscaping Crew [26 h] | 4,358.98 | 1.3.7.30 | CONS | CONS | ZONE-3 | REALM | SOFTSCAPE |
| CON-Z3-LS-TR-190 |  | Instalaltion of Jacaranda | 4d | 2017-08-01 | 2017-08-06 | CON-Z3-LS-TR-180 SS+1.6d | 117.2d | 0d | Soft Landscaping Crew [26 h] | 7,122.77 | 1.3.7.30 | CONS | CONS | ZONE-3 | REALM | SOFTSCAPE |
| CON-Z3-LS-TR-200 |  | Instalaltion of Cassia Fistula | 2.4d | 2017-08-03 | 2017-08-06 | CON-Z3-LS-TR-190 SS+1.6d | 117.2d | 0d | Soft Landscaping Crew [26 h] | 8,505.98 | 1.3.7.30 | CONS | CONS | ZONE-3 | REALM | SOFTSCAPE |
| CON-Z3-LS-TR-210 |  | Instalaltion of Al Bizia Jublibrissin | 2.4d | 2017-08-05 | 2017-08-07 | CON-Z3-LS-TR-200 SS+1.6d | 117.2d | 0d | Soft Landscaping Crew [26 h] | 10,766.29 | 1.3.7.30 | CONS | CONS | ZONE-3 | REALM | SOFTSCAPE |
| CON-Z3-LS-TR-220 |  | Instalaltion of Chamarops Humilis | 2.4d | 2017-08-07 | 2017-08-09 | CON-Z3-LS-TR-210 SS+1.6d | 117.2d | 0d | Soft Landscaping Crew [26 h] | 20,867.48 | 1.3.7.30 | CONS | CONS | ZONE-3 | REALM | SOFTSCAPE |
| CON-Z3-LS-TR-230 |  | Instalaltion of Cycas Revolute | 28d | 2017-08-08 | 2017-09-14 | CON-Z3-LS-TR-220 SS+1.6d | 117.2d | 0d | Soft Landscaping Crew [26 h] | 3,776.02 | 1.3.7.30 | CONS | CONS | ZONE-3 | REALM | SOFTSCAPE |

Notes:
- CON-Z3-LS-SH-130: Expenses: (New Expense Item) 24928.9
- CON-Z3-LS-SH-140: Expenses: (New Expense Item) 24928.9
- CON-Z3-LS-SH-150: Expenses: (New Expense Item) 24928.9
- CON-Z3-LS-SH-160: Expenses: (New Expense Item) 24928.9
- CON-Z3-LS-SH-170: Expenses: (New Expense Item) 24928.9
- CON-Z3-LS-PL-140: Expenses: (New Expense Item) 13087.7
- CON-Z3-LS-PL-150: Expenses: (New Expense Item) 13087.7
- CON-Z3-LS-PL-160: Expenses: (New Expense Item) 13087.7
- CON-Z3-LS-PL-170: Expenses: (New Expense Item) 13087.7
- CON-Z3-LS-PL-180: Expenses: (New Expense Item) 13087.7
- CON-Z3-LS-PL-190: Expenses: (New Expense Item) 13087.7
- CON-Z3-LS-PL-200: Expenses: (New Expense Item) 8725.11
- CON-Z3-LS-GRAV-20: Expenses: (New Expense Item) 12464.4
- CON-Z3-LS-GRAS-20: Expenses: (New Expense Item) 12464.4
- CON-Z3-LS-SAND-20: Expenses: (New Expense Item) 12464.4
- CON-Z3-LS-TR-180: Expenses: (New Expense Item) 4358.98
- CON-Z3-LS-TR-190: Expenses: (New Expense Item) 7122.77
- CON-Z3-LS-TR-200: Expenses: (New Expense Item) 8505.98
- CON-Z3-LS-TR-210: Expenses: (New Expense Item) 10766.3
- CON-Z3-LS-TR-220: Expenses: (New Expense Item) 20867.5
- CON-Z3-LS-TR-230: Expenses: (New Expense Item) 3776.02

| ID | WBS | Activity | Duration | Start | Finish | Predecessors | Total float | Free float | Resources | Cost | RPI_P2 - BOQ ITEMS | RPI_P2 - CONSTRUCTION | RPI_P2 - PHASE | RPI_P2 - ZONES | RPI_P2 - AREAS | RPI_P2 - DISCIPLINE / WORK TYPE |
| --- | --- | --- | --- | --- | --- | --- | --- | --- | --- | --- | --- | --- | --- | --- | --- | --- |
|  | 2 | **Shurbs** |  | 2017-08-10 | 2017-08-20 |  |  |  |  |  |  |  |  |  |  |  |
| CON-Z3-LS-SH-180 |  | Installation of bougainvilea SP | 1.6d | 2017-08-10 | 2017-08-12 | CON-Z3-LS-TR-230 SS+1.6d | 117.2d | 0d | Soft Landscaping Crew [26 h] | 8,309.63 | 1.3.7.30 | CONS | CONS | ZONE-3 | REALM | SOFTSCAPE |
| CON-Z3-LS-SH-190 |  | Installation of Caesalpinia Pulchrrima | 1.6d | 2017-08-13 | 2017-08-14 | CON-Z3-LS-SH-180 SS+1.6d | 117.2d | 0d | Soft Landscaping Crew [26 h] | 8,309.63 | 1.3.7.30 | CONS | CONS | ZONE-3 | REALM | SOFTSCAPE |
| CON-Z3-LS-SH-200 |  | Installation of Tecoma Stans | 1.6d | 2017-08-14 | 2017-08-16 | CON-Z3-LS-SH-190 SS+1.6d | 117.2d | 0d | Soft Landscaping Crew [26 h] | 8,309.63 | 1.3.7.30 | CONS | CONS | ZONE-3 | REALM | SOFTSCAPE |
| CON-Z3-LS-SH-210 |  | Instalaltion of City Krzyzes | 1.6d | 2017-08-16 | 2017-08-17 | CON-Z3-LS-SH-200 SS+1.6d | 117.2d | 0d | Soft Landscaping Crew [26 h] | 8,309.63 | 1.3.7.30 | CONS | CONS | ZONE-3 | REALM | SOFTSCAPE |
| CON-Z3-LS-SH-220 |  | Installation of Hibiscus Roas-Sinensis | 1.6d | 2017-08-17 | 2017-08-20 | CON-Z3-LS-SH-210 SS+1.6d | 117.2d | 0d | Soft Landscaping Crew [26 h] | 8,309.63 | 1.3.7.30 | CONS | CONS | ZONE-3 | REALM | SOFTSCAPE |
|  | 3 | **Ground Covers** |  | 2017-08-20 | 2017-09-14 |  |  |  |  |  |  |  |  |  |  |  |
|  | 1 | **Plants** |  | 2017-08-20 | 2017-09-06 |  |  |  |  |  |  |  |  |  |  |  |
| CON-Z3-LS-PL-210 |  | Installation of Agva | 1.6d | 2017-08-20 | 2017-08-21 | CON-Z3-LS-SH-220 SS+1.6d | 117.2d | 0d | Soft Landscaping Crew [26 h] | 4,362.55 | 1.3.7.30 | CONS | CONS | ZONE-3 | REALM | SOFTSCAPE |
| CON-Z3-LS-PL-220 |  | Installation of Aloe Vera | 1.6d | 2017-08-22 | 2017-08-23 | CON-Z3-LS-PL-210 SS+1.6d | 117.2d | 0d | Soft Landscaping Crew [26 h] | 4,362.55 | 1.3.7.30 | CONS | CONS | ZONE-3 | REALM | SOFTSCAPE |
| CON-Z3-LS-PL-230 |  | Installation of Cenchrus Ciliaris | 1.6d | 2017-08-23 | 2017-08-26 | CON-Z3-LS-PL-220 SS+1.6d | 117.2d | 0d | Soft Landscaping Crew [26 h] | 4,362.55 | 1.3.7.30 | CONS | CONS | ZONE-3 | REALM | SOFTSCAPE |
| CON-Z3-LS-PL-240 |  | Installation of Pennisetum Setaceum | 1.6d | 2017-08-26 | 2017-08-27 | CON-Z3-LS-PL-230 SS+1.6d | 117.2d | 0d | Soft Landscaping Crew [26 h] | 4,362.55 | 1.3.7.30 | CONS | CONS | ZONE-3 | REALM | SOFTSCAPE |
| CON-Z3-LS-PL-250 |  | Instalaltion of Cytsdon Dactylon | 1.6d | 2017-08-27 | 2017-08-29 | CON-Z3-LS-PL-240 SS+1.6d | 117.2d | 0d | Soft Landscaping Crew [26 h] | 4,362.55 | 1.3.7.30 | CONS | CONS | ZONE-3 | REALM | SOFTSCAPE |
| CON-Z3-LS-PL-260 |  | Installation of Carissa Grandiflora | 1.6d | 2017-08-29 | 2017-08-30 | CON-Z3-LS-PL-250 SS+1.6d | 117.2d | 0d | Soft Landscaping Crew [26 h] | 4,362.55 | 1.3.7.30 | CONS | CONS | ZONE-3 | REALM | SOFTSCAPE |
| CON-Z3-LS-PL-270 |  | Instalaltion of Wedelia Trilobata | 1.6d | 2017-09-05 | 2017-09-06 | CON-Z3-LS-PL-260 SS+1.6d | 117.2d | 0d | Soft Landscaping Crew [26 h] | 2,908.37 | 1.3.7.30 | CONS | CONS | ZONE-3 | REALM | SOFTSCAPE |
|  | 2 | **Gravel Mulch Paving & Natural Stone Boulders** |  | 2017-09-06 | 2017-09-10 |  |  |  |  |  |  |  |  |  |  |  |
| CON-Z3-LS-GRAV-30 |  | Instalaltion of Gravel Mulch and Natural Stone Boulders | 3.2d | 2017-09-06 | 2017-09-10 | CON-Z3-LS-PL-270 SS+1.6d | 117.2d | 0d | Soft Landscaping Crew [83.2 h] | 4,154.81 | 1.3.7.30 | CONS | CONS | ZONE-3 | REALM | SOFTSCAPE |
|  | 3 | **Grass** |  | 2017-09-09 | 2017-09-13 |  |  |  |  |  |  |  |  |  |  |  |
| CON-Z3-LS-GRAS-30 |  | Instalaltion of Grass | 4d | 2017-09-09 | 2017-09-13 | CON-Z3-LS-GRAV-30 SS+1.6d | 117.2d | 0d | Soft Landscaping Crew [260 h] | 4,154.81 | 1.3.7.30 | CONS | CONS | ZONE-3 | REALM | SOFTSCAPE |
|  | 4 | **Sand Fill / Play Ground Sand** |  | 2017-09-10 | 2017-09-14 |  |  |  |  |  |  |  |  |  |  |  |
| CON-Z3-LS-SAND-30 |  | Laying of Sandfilling 10mm thich and Playground Sand | 4d | 2017-09-10 | 2017-09-14 | CON-Z3-LS-GRAS-30 SS+1.6d, PR-Z3-LW-LS-107-0080, CON-Z3-LS-SAND-20 SS | 117.2d | 0d | Common Labor / Helper [312 h]; Operator - Bobcat [52 h]; Driver - Water Tanker [52 h]; Operator - JCB [52 h]; Bobcat [56 h]; Water Tanker [56 h]; JCB [56 h] | 4,154.81 | 1.3.7.30 | CONS | CONS | ZONE-3 | REALM | SOFTSCAPE |
|  | 5 | **Street Lighting Works in Public Realms (Walkway Lighting and Power)** |  | 2017-02-09 | 2017-07-12 |  |  |  |  |  |  |  |  |  |  |  |
|  | 1 | **Street Lighting Work for Area-1 (Public Realms Between Road-A and Road-4)** |  | 2017-02-09 | 2017-06-18 |  |  |  |  |  |  |  |  |  |  |  |
|  | 1 | **Street Lighting Cabling (LV)** |  | 2017-02-09 | 2017-03-16 |  |  |  |  |  |  |  |  |  |  |  |
| CON-Z3-SL-LS-0010 |  | Excavation for Street Lighting Trench | 6.4d | 2017-02-09 | 2017-02-16 | CON-Z3-SF-LS-GE-0010 FS+64d | 168.6d | 0d | Operator - Excavator [26 h]; Excavator [28 h] | 7,478.66 | 1.3.7.30 | CONS | CONS | ZONE-3 | REALM | ELEC |
| CON-Z3-SL-LS-0020 |  | Sand bedding | 4d | 2017-02-16 | 2017-02-21 | CON-Z3-SL-LS-0010 | 233.4d | 0d | Common Labor / Helper [104 h]; Operator - Loader [26 h]; Driver - Dump Truck [26 h]; Operator - Bobcat [26 h]; Operator - JCB [26 h]; Loader [28 h]; Dump Truck [28 h]; Bobcat [28 h]; JCB [28 h] | 4,985.78 | 1.3.7.30 | CONS | CONS | ZONE-3 | REALM | ELEC |
| CON-Z3-SL-LS-0030 |  | Instalaltion of LV Cables | 4d | 2017-02-21 | 2017-02-26 | CON-Z3-SL-LS-0020, PR-Z3-UT-EL-155-0080 | 233.4d | 0d | LC Crew [52 h] | 14,957.33 | 1.3.7.30 | CONS | CONS | ZONE-3 | REALM | ELEC |
| CON-Z3-SL-LS-0040 |  | Sandfillling,Red Tiles and Warning Tape | 8d | 2017-02-26 | 2017-03-07 | CON-Z3-SL-LS-0030 | 233.4d | 0d | Common Labor / Helper [78 h]; Block Mason [52 h]; Tiling Crew [52 h] | 12,464.44 | 1.3.7.30 | CONS | CONS | ZONE-3 | REALM | ELEC |
| CON-Z3-SL-LS-0050 |  | Final Backfilling | 8d | 2017-03-07 | 2017-03-16 | CON-Z3-SL-LS-0040 | 233.4d | 0d | Common Labor / Helper [104 h]; Operator - Loader [26 h]; Driver - Dump Truck [26 h]; Operator - Bobcat [26 h]; Operator - Asphalt Compactor / Roller [26 h]; Operator - Roller-Compactor (2~10 Ton) [26 h]; Driver - Water Tanker [26 h]; Operator - JCB [26 h]; Loader [28 h]; Dump Truck [28 h]; Bobcat [28 h]; Roller-Compactor (2~10 Ton) [28 h]; Roller-Compactor (25 Ton) [28 h]; Water Tanker [28 h] | 9,971.55 | 1.3.7.30 | CONS | CONS | ZONE-3 | REALM | ELEC |

Notes:
- CON-Z3-LS-SH-180: Expenses: (New Expense Item) 8309.63
- CON-Z3-LS-SH-190: Expenses: (New Expense Item) 8309.63
- CON-Z3-LS-SH-200: Expenses: (New Expense Item) 8309.63
- CON-Z3-LS-SH-210: Expenses: (New Expense Item) 8309.63
- CON-Z3-LS-SH-220: Expenses: (New Expense Item) 8309.63
- CON-Z3-LS-PL-210: Expenses: (New Expense Item) 4362.55
- CON-Z3-LS-PL-220: Expenses: (New Expense Item) 4362.55
- CON-Z3-LS-PL-230: Expenses: (New Expense Item) 4362.55
- CON-Z3-LS-PL-240: Expenses: (New Expense Item) 4362.55
- CON-Z3-LS-PL-250: Expenses: (New Expense Item) 4362.55
- CON-Z3-LS-PL-260: Expenses: (New Expense Item) 4362.55
- CON-Z3-LS-PL-270: Expenses: (New Expense Item) 2908.37
- CON-Z3-LS-GRAV-30: Expenses: (New Expense Item) 4154.81
- CON-Z3-LS-GRAS-30: Expenses: (New Expense Item) 4154.81
- CON-Z3-LS-SAND-30: Expenses: (New Expense Item) 4154.81
- CON-Z3-SL-LS-0010: Expenses: (New Expense Item) 7478.66
- CON-Z3-SL-LS-0020: Expenses: (New Expense Item) 4985.78
- CON-Z3-SL-LS-0030: Expenses: (New Expense Item) 14957.3
- CON-Z3-SL-LS-0040: Expenses: (New Expense Item) 12464.4
- CON-Z3-SL-LS-0050: Expenses: (New Expense Item) 9971.55

| ID | WBS | Activity | Duration | Start | Finish | Predecessors | Total float | Free float | Resources | Cost | RPI_P2 - BOQ ITEMS | RPI_P2 - CONSTRUCTION | RPI_P2 - PHASE | RPI_P2 - ZONES | RPI_P2 - AREAS | RPI_P2 - DISCIPLINE / WORK TYPE |
| --- | --- | --- | --- | --- | --- | --- | --- | --- | --- | --- | --- | --- | --- | --- | --- | --- |
|  | 2 | **Street Lighting Foundations,Poles and Lighting Fixures)** |  | 2017-02-16 | 2017-06-18 |  |  |  |  |  |  |  |  |  |  |  |
| CON-Z3-SL-LS-0060 |  | Instalaltion of Concrete Foundations for 10m Poles | 8d | 2017-02-16 | 2017-02-26 | CON-Z3-SL-LS-0010 | 181.4d | 0d | Common Labor / Helper [52 h]; Operator - Mobile Crane [26 h]; Driver - Flat Bed Trailer [26 h]; Mobile Crane ( 25-60 Ton) [28 h]; Flat Bed Trailer [28 h] | 13,960.17 | 1.3.7.30 | CONS | CONS | ZONE-3 | REALM | ELEC |
| CON-Z3-SL-LS-0070 |  | Installation of Lighting Poles (10m) | 12d | 2017-02-26 | 2017-03-12 | CON-Z3-SL-LS-0060 | 181.4d | 0d | Common Labor / Helper [52 h]; Operator - Mobile Crane [26 h]; Driver - Flat Bed Trailer [26 h]; Mobile Crane ( 25-60 Ton) [28 h]; Flat Bed Trailer [28 h] | 13,960.17 | 1.3.7.30 | CONS | CONS | ZONE-3 | REALM | ELEC |
| CON-Z3-SL-LS-0090 |  | Instalaltion of Concrete Foundations for 8m Poles | 4d | 2017-02-26 | 2017-03-02 | CON-Z3-SL-LS-0060 | 249.4d | 0d | Common Labor / Helper [52 h]; Operator - Mobile Crane [26 h]; Driver - Flat Bed Trailer [26 h]; Mobile Crane ( 25-60 Ton) [28 h]; Flat Bed Trailer [28 h] | 13,960.17 | 1.3.7.30 | CONS | CONS | ZONE-3 | REALM | ELEC |
| CON-Z3-SL-LS-0100 |  | Installation of Lighting Poles (8m) | 4d | 2017-03-02 | 2017-03-07 | CON-Z3-SL-LS-0090 | 257.4d | 76d | Common Labor / Helper [52 h]; Operator - Mobile Crane [26 h]; Driver - Flat Bed Trailer [26 h]; Mobile Crane ( 25-60 Ton) [28 h]; Flat Bed Trailer [28 h] | 13,960.17 | 1.3.7.30 | CONS | CONS | ZONE-3 | REALM | ELEC |
| CON-Z3-SL-LS-0120 |  | Instalaltion of Concrete Foundations for Solar Bolard Lighting | 4d | 2017-03-25 | 2017-03-29 | PR-Z3-EW-EW-58-0080, CON-Z3-SL-LS-0090 | 230.6d | 0d | Flat Bed Trailer [28 h]; Common Labor / Helper [52 h]; Operator - Mobile Crane [26 h]; Driver - Flat Bed Trailer [26 h]; Mobile Crane ( 25-60 Ton) [28 h] | 13,960.17 | 1.3.7.30 | CONS | CONS | ZONE-3 | REALM | ELEC |
| CON-Z3-SL-LS-0140 |  | Instalaltion of Concrete Foundations for Solar Globe Lighting | 4d | 2017-03-29 | 2017-04-03 | PR-Z3-EW-EW-58-0080, CON-Z3-SL-LS-0120 | 230.6d | 0d | Common Labor / Helper [52 h]; Operator - Mobile Crane [26 h]; Driver - Flat Bed Trailer [26 h]; Mobile Crane ( 25-60 Ton) [28 h]; Flat Bed Trailer [28 h] | 13,960.17 | 1.3.7.30 | CONS | CONS | ZONE-3 | REALM | ELEC |
| CON-Z3-SL-LS-0160 |  | Instalaltion of Concrete Foundations for Walway Lightings | 4d | 2017-04-03 | 2017-04-08 | CON-Z3-SL-LS-0140 | 230.6d | 49.2d | Common Labor / Helper [52 h]; Operator - Mobile Crane [26 h]; Driver - Flat Bed Trailer [26 h]; Mobile Crane ( 25-60 Ton) [28 h]; Flat Bed Trailer [28 h] | 13,960.17 | 1.3.7.30 | CONS | CONS | ZONE-3 | REALM | ELEC |
| CON-Z3-SL-LS-0080 |  | Installation of Lighting Fixures for 10m Lighting Poles | 8d | 2017-06-04 | 2017-06-13 | CON-Z3-SL-LS-0070 FS+72d | 181.4d | 0d | Electrician [104 h]; LC Crew [52 h]; Operator - Manlift (Boom Truck) [26 h]; Manlift (Boom Truck) [28 h] | 13,960.17 | 1.3.7.30 | CONS | CONS | ZONE-3 | REALM | ELEC |
| CON-Z3-SL-LS-0110 |  | Installation of Lighting Fixures for 8m Lighting Poles | 4d | 2017-06-04 | 2017-06-08 | CON-Z3-SL-LS-0100, CON-Z3-SL-LS-0080 SS | 181.4d | 0d | Electrician [104 h]; LC Crew [52 h]; Operator - Manlift (Boom Truck) [26 h]; Manlift (Boom Truck) [28 h] | 13,960.17 | 1.3.7.30 | CONS | CONS | ZONE-3 | REALM | ELEC |
| CON-Z3-SL-LS-0130 |  | Instalaltion of Solar Bolard Lightings | 4d | 2017-06-04 | 2017-06-08 | CON-Z3-SL-LS-0110 SS, PR-Z3-CW-MS-30-0080, CON-Z3-SL-LS-0120 | 181.4d | 0d | Electrician [52 h]; LC Crew [52 h] | 13,960.17 | 1.3.7.30 | CONS | CONS | ZONE-3 | REALM | ELEC |
| CON-Z3-SL-LS-0150 |  | Instalaltion of Solar Globe Lightings | 4d | 2017-06-04 | 2017-06-08 | CON-Z3-SL-LS-0140, CON-Z3-SL-LS-0130 SS | 181.4d | 0d | Electrician [52 h]; LC Crew [52 h] | 13,960.17 | 1.3.7.30 | CONS | CONS | ZONE-3 | REALM | ELEC |
| CON-Z3-SL-LS-0170 |  | Instalaltion of Walway Lightings | 4d | 2017-06-04 | 2017-06-08 | PR-Z3-EW-EW-57-0080, CON-Z3-SL-LS-0150 SS, CON-Z3-SL-LS-0160 | 181.4d | 0d | Electrician [52 h]; LC Crew [52 h] | 13,960.17 | 1.3.7.30 | CONS | CONS | ZONE-3 | REALM | ELEC |
| CON-Z3-SL-LS-0180 |  | Termination and Grounding of LV Cables for Lighting Fixures | 8d | 2017-06-08 | 2017-06-18 | CON-Z3-SL-LS-0190 SS, CON-Z3-SL-LS-0170 | 181.4d | 6.4d | Electrician [52 h]; LC Crew [52 h] | 13,960.17 | 1.3.7.30 | CONS | CONS | ZONE-3 | REALM | ELEC |
| CON-Z3-SL-LS-0190 |  | Installation of Solar Panels and Batteries | 4d | 2017-06-08 | 2017-06-13 | CON-Z3-SL-LS-0170 | 181.4d | 0d | Electrician [52 h]; LC Crew [52 h] | 17,948.8 | 1.3.7.30 | CONS | CONS | ZONE-3 | REALM | ELEC |
|  | 3 | **Street Lighting Work for Area-2 (Public Realms Between Road-4 and Road-B)** |  | 2017-02-16 | 2017-06-25 |  |  |  |  |  |  |  |  |  |  |  |
|  | 1 | **Street Lighting Cabling (LV)** |  | 2017-02-16 | 2017-03-26 |  |  |  |  |  |  |  |  |  |  |  |
| CON-Z3-SL-LS-190 |  | Excavation for Street Lighting Trench | 6.4d | 2017-02-16 | 2017-02-23 | CON-Z3-SL-LS-0010 | 168.6d | 0d | Operator - Excavator [26 h] | 7,478.66 | 1.3.7.30 | CONS | CONS | ZONE-3 | REALM | ELEC |
| CON-Z3-SL-LS-200 |  | Sand bedding | 4d | 2017-02-25 | 2017-02-28 | CON-Z3-SL-LS-190 | 235d | 0d | Common Labor / Helper [104 h]; Operator - Loader [26 h]; Driver - Dump Truck [26 h]; Operator - Bobcat [26 h]; Operator - JCB [26 h]; Loader [28 h]; Dump Truck [28 h]; Bobcat [28 h]; JCB [28 h] | 4,985.78 | 1.3.7.30 | CONS | CONS | ZONE-3 | REALM | ELEC |
| CON-Z3-SL-LS-210 |  | Instalaltion of LV Cables | 4d | 2017-03-01 | 2017-03-05 | CON-Z3-SL-LS-200 | 235d | 0d | LC Crew [52 h] | 14,957.33 | 1.3.7.30 | CONS | CONS | ZONE-3 | REALM | ELEC |
| CON-Z3-SL-LS-220 |  | Sandfillling,Red Tiles and Warning Tape | 8d | 2017-03-06 | 2017-03-14 | CON-Z3-SL-LS-210 | 235d | 1.6d | Common Labor / Helper [78 h]; Block Mason [52 h]; Tiling Crew [52 h] | 12,464.44 | 1.3.7.30 | CONS | CONS | ZONE-3 | REALM | ELEC |
| CON-Z3-SL-LS-230 |  | Final Backfilling | 8d | 2017-03-16 | 2017-03-26 | CON-Z3-SL-LS-0050, CON-Z3-SL-LS-220 | 233.4d | 0d | Common Labor / Helper [104 h]; Operator - Loader [26 h]; Driver - Dump Truck [26 h]; Operator - Bobcat [26 h]; Operator - Asphalt Compactor / Roller [26 h]; Operator - Roller-Compactor (2~10 Ton) [26 h]; Driver - Water Tanker [26 h]; Operator - JCB [26 h]; Loader [28 h]; Dump Truck [28 h]; Bobcat [28 h]; Roller-Compactor (2~10 Ton) [28 h]; Roller-Compactor (25 Ton) [28 h]; Water Tanker [28 h] | 9,971.55 | 1.3.7.30 | CONS | CONS | ZONE-3 | REALM | ELEC |
|  | 2 | **Street Lighting Foundations,Poles and Lighting Fixures)** |  | 2017-02-25 | 2017-06-25 |  |  |  |  |  |  |  |  |  |  |  |
| CON-Z3-SL-LS-240 |  | Instalaltion of Concrete Foundations for 10m Poles | 8d | 2017-02-25 | 2017-03-05 | CON-Z3-SL-LS-190 | 175d | 0d | Common Labor / Helper [52 h]; Operator - Mobile Crane [26 h]; Driver - Flat Bed Trailer [26 h]; Mobile Crane ( 25-60 Ton) [28 h]; Flat Bed Trailer [28 h] | 13,960.17 | 1.3.7.30 | CONS | CONS | ZONE-3 | REALM | ELEC |
| CON-Z3-SL-LS-250 |  | Installation of Lighting Poles (10m) | 12d | 2017-03-06 | 2017-03-19 | CON-Z3-SL-LS-240 | 175d | 0d | Common Labor / Helper [52 h]; Operator - Mobile Crane [26 h]; Driver - Flat Bed Trailer [26 h]; Mobile Crane ( 25-60 Ton) [28 h]; Flat Bed Trailer [28 h] | 13,960.17 | 1.3.7.30 | CONS | CONS | ZONE-3 | REALM | ELEC |
| CON-Z3-SL-LS-270 |  | Instalaltion of Concrete Foundations for 8m Poles | 4d | 2017-03-06 | 2017-03-09 | CON-Z3-SL-LS-240 | 243d | 0d | Common Labor / Helper [52 h]; Operator - Mobile Crane [26 h]; Driver - Flat Bed Trailer [26 h]; Mobile Crane ( 25-60 Ton) [28 h]; Flat Bed Trailer [28 h] | 13,960.17 | 1.3.7.30 | CONS | CONS | ZONE-3 | REALM | ELEC |
| CON-Z3-SL-LS-280 |  | Installation of Lighting Poles (8m) | 4d | 2017-03-11 | 2017-03-14 | CON-Z3-SL-LS-270 | 251d | 76d | Common Labor / Helper [52 h]; Operator - Mobile Crane [26 h]; Driver - Flat Bed Trailer [26 h]; Mobile Crane ( 25-60 Ton) [28 h]; Flat Bed Trailer [28 h] | 13,960.17 | 1.3.7.30 | CONS | CONS | ZONE-3 | REALM | ELEC |
| CON-Z3-SL-LS-300 |  | Instalaltion of Concrete Foundations for Solar Bolard Lighting | 4d | 2017-03-11 | 2017-03-14 | CON-Z3-SL-LS-270 | 243d | 0d | Common Labor / Helper [52 h]; Operator - Mobile Crane [26 h]; Driver - Flat Bed Trailer [26 h]; Mobile Crane ( 25-60 Ton) [28 h]; Flat Bed Trailer [28 h] | 13,960.17 | 1.3.7.30 | CONS | CONS | ZONE-3 | REALM | ELEC |
| CON-Z3-SL-LS-320 |  | Instalaltion of Concrete Foundations for Solar Globe Lighting | 4d | 2017-03-15 | 2017-03-19 | CON-Z3-SL-LS-300 | 243d | 0d | Common Labor / Helper [52 h]; Operator - Mobile Crane [26 h]; Driver - Flat Bed Trailer [26 h]; Mobile Crane ( 25-60 Ton) [28 h]; Flat Bed Trailer [28 h] | 13,960.17 | 1.3.7.30 | CONS | CONS | ZONE-3 | REALM | ELEC |
| CON-Z3-SL-LS-350 |  | Instalaltion of Concrete Foundations for Walway Lightings | 4d | 2017-03-20 | 2017-03-23 | CON-Z3-SL-LS-320 | 243d | 68d | Common Labor / Helper [52 h]; Operator - Mobile Crane [26 h]; Driver - Flat Bed Trailer [26 h]; Mobile Crane ( 25-60 Ton) [28 h]; Flat Bed Trailer [28 h] | 13,960.17 | 1.3.7.30 | CONS | CONS | ZONE-3 | REALM | ELEC |
| CON-Z3-SL-LS-260 |  | Installation of Lighting Fixures for 10m Lighting Poles | 8d | 2017-06-12 | 2017-06-20 | CON-Z3-SL-LS-250 FS+72d | 175d | 0d | Electrician [104 h]; LC Crew [52 h]; Operator - Manlift (Boom Truck) [26 h]; Manlift (Boom Truck) [28 h] | 13,960.17 | 1.3.7.30 | CONS | CONS | ZONE-3 | REALM | ELEC |
| CON-Z3-SL-LS-290 |  | Installation of Lighting Fixures for 8m Lighting Poles | 4d | 2017-06-12 | 2017-06-15 | CON-Z3-SL-LS-280, CON-Z3-SL-LS-260 SS | 175d | 0d | Electrician [104 h]; LC Crew [52 h]; Operator - Manlift (Boom Truck) [26 h]; Manlift (Boom Truck) [28 h] | 13,960.17 | 1.3.7.30 | CONS | CONS | ZONE-3 | REALM | ELEC |
| CON-Z3-SL-LS-310 |  | Instalaltion of Solar Bolard Lightings | 4d | 2017-06-12 | 2017-06-15 | CON-Z3-SL-LS-290 SS, CON-Z3-SL-LS-300 | 175d | 0d | Electrician [52 h]; LC Crew [52 h] | 13,960.17 | 1.3.7.30 | CONS | CONS | ZONE-3 | REALM | ELEC |
| CON-Z3-SL-LS-330 |  | Instalaltion of Solar Globe Lightings | 4d | 2017-06-12 | 2017-06-15 | CON-Z3-SL-LS-310 SS, CON-Z3-SL-LS-320 | 175d | 0d | Electrician [52 h]; LC Crew [52 h] | 13,960.17 | 1.3.7.30 | CONS | CONS | ZONE-3 | REALM | ELEC |
| CON-Z3-SL-LS-340 |  | Instalaltion of Walway Lightings | 4d | 2017-06-12 | 2017-06-15 | CON-Z3-SL-LS-350, CON-Z3-SL-LS-330 SS | 175d | 0d | Electrician [52 h]; LC Crew [52 h] | 13,960.17 | 1.3.7.30 | CONS | CONS | ZONE-3 | REALM | ELEC |
| CON-Z3-SL-LS-360 |  | Termination and Grounding of LV Cables for Lighting Fixures | 8d | 2017-06-17 | 2017-06-25 | CON-Z3-SL-LS-0180 SS, CON-Z3-SL-LS-340 | 175d | 6.4d | Electrician [52 h]; LC Crew [52 h] | 13,960.17 | 1.3.7.30 | CONS | CONS | ZONE-3 | REALM | ELEC |
| CON-Z3-SL-LS-370 |  | Installation of Solar Panels and Batteries | 4d | 2017-06-17 | 2017-06-20 | CON-Z3-SL-LS-340, CON-Z3-SL-LS-0190 SS | 183d | 6.4d | Electrician [52 h]; LC Crew [52 h] | 17,948.8 | 1.3.7.30 | CONS | CONS | ZONE-3 | REALM | ELEC |

Notes:
- CON-Z3-SL-LS-0060: Expenses: (New Expense Item) 13960.2
- CON-Z3-SL-LS-0070: Expenses: (New Expense Item) 13960.2
- CON-Z3-SL-LS-0090: Expenses: (New Expense Item) 13960.2
- CON-Z3-SL-LS-0100: Expenses: (New Expense Item) 13960.2
- CON-Z3-SL-LS-0120: Expenses: (New Expense Item) 13960.2
- CON-Z3-SL-LS-0140: Expenses: (New Expense Item) 13960.2
- CON-Z3-SL-LS-0160: Expenses: (New Expense Item) 13960.2
- CON-Z3-SL-LS-0080: Expenses: (New Expense Item) 13960.2
- CON-Z3-SL-LS-0110: Expenses: (New Expense Item) 13960.2
- CON-Z3-SL-LS-0130: Expenses: (New Expense Item) 13960.2
- CON-Z3-SL-LS-0150: Expenses: (New Expense Item) 13960.2
- CON-Z3-SL-LS-0170: Expenses: (New Expense Item) 13960.2
- CON-Z3-SL-LS-0180: Expenses: (New Expense Item) 13960.2
- CON-Z3-SL-LS-0190: Expenses: (New Expense Item) 17948.8
- CON-Z3-SL-LS-190: Expenses: (New Expense Item) 7478.66
- CON-Z3-SL-LS-200: Expenses: (New Expense Item) 4985.78
- CON-Z3-SL-LS-210: Expenses: (New Expense Item) 14957.3
- CON-Z3-SL-LS-220: Expenses: (New Expense Item) 12464.4
- CON-Z3-SL-LS-230: Expenses: (New Expense Item) 9971.55
- CON-Z3-SL-LS-240: Expenses: (New Expense Item) 13960.2
- CON-Z3-SL-LS-250: Expenses: (New Expense Item) 13960.2
- CON-Z3-SL-LS-270: Expenses: (New Expense Item) 13960.2
- CON-Z3-SL-LS-280: Expenses: (New Expense Item) 13960.2
- CON-Z3-SL-LS-300: Expenses: (New Expense Item) 13960.2
- CON-Z3-SL-LS-320: Expenses: (New Expense Item) 13960.2
- CON-Z3-SL-LS-350: Expenses: (New Expense Item) 13960.2
- CON-Z3-SL-LS-260: Expenses: (New Expense Item) 13960.2
- CON-Z3-SL-LS-290: Expenses: (New Expense Item) 13960.2
- CON-Z3-SL-LS-310: Expenses: (New Expense Item) 13960.2
- CON-Z3-SL-LS-330: Expenses: (New Expense Item) 13960.2
- CON-Z3-SL-LS-340: Expenses: (New Expense Item) 13960.2
- CON-Z3-SL-LS-360: Expenses: (New Expense Item) 13960.2
- CON-Z3-SL-LS-370: Expenses: (New Expense Item) 17948.8

| ID | WBS | Activity | Duration | Start | Finish | Predecessors | Total float | Free float | Resources | Cost | RPI_P2 - BOQ ITEMS | RPI_P2 - CONSTRUCTION | RPI_P2 - PHASE | RPI_P2 - ZONES | RPI_P2 - AREAS | RPI_P2 - DISCIPLINE / WORK TYPE |
| --- | --- | --- | --- | --- | --- | --- | --- | --- | --- | --- | --- | --- | --- | --- | --- | --- |
|  | 2 | **Street Lighting Work for Area-3 (Public Realms Between Road-B and Road-A)** |  | 2017-02-25 | 2017-07-08 |  |  |  |  |  |  |  |  |  |  |  |
|  | 1 | **Street Lighting Cabling (LV)** |  | 2017-02-25 | 2017-04-04 |  |  |  |  |  |  |  |  |  |  |  |
| CON-Z3-SL-LS-380 |  | Excavation for Street Lighting Trench | 6.4d | 2017-02-25 | 2017-03-04 | CON-Z3-SL-LS-190 | 168.6d | 0d | Operator - Excavator [26 h] | 7,478.66 | 1.3.7.30 | CONS | CONS | ZONE-3 | REALM | ELEC |
| CON-Z3-SL-LS-390 |  | Sand bedding | 4d | 2017-03-04 | 2017-03-08 | CON-Z3-SL-LS-380 | 236.6d | 0d | Operator - Loader [26 h]; Driver - Dump Truck [26 h]; Operator - Bobcat [26 h]; Operator - JCB [26 h]; Loader [28 h]; Dump Truck [28 h]; Bobcat [28 h]; JCB [28 h]; Common Labor / Helper [104 h] | 4,985.78 | 1.3.7.30 | CONS | CONS | ZONE-3 | REALM | ELEC |
| CON-Z3-SL-LS-400 |  | Instalaltion of LV Cables | 4d | 2017-03-08 | 2017-03-13 | CON-Z3-SL-LS-390 | 236.6d | 0d | LC Crew [52 h] | 14,957.33 | 1.3.7.30 | CONS | CONS | ZONE-3 | REALM | ELEC |
| CON-Z3-SL-LS-410 |  | Sandfillling,Red Tiles and Warning Tape | 8d | 2017-03-13 | 2017-03-22 | CON-Z3-SL-LS-400 | 236.6d | 3.2d | Common Labor / Helper [78 h]; Block Mason [52 h]; Tiling Crew [52 h] | 12,464.44 | 1.3.7.30 | CONS | CONS | ZONE-3 | REALM | ELEC |
| CON-Z3-SL-LS-420 |  | Final Backfilling | 8d | 2017-03-26 | 2017-04-04 | CON-Z3-SL-LS-230, CON-Z3-SL-LS-410 | 233.4d | 0d | Common Labor / Helper [104 h]; Operator - Loader [26 h]; Driver - Dump Truck [26 h]; Operator - Bobcat [26 h]; Operator - Asphalt Compactor / Roller [26 h]; Operator - Roller-Compactor (2~10 Ton) [26 h]; Driver - Water Tanker [26 h]; Operator - JCB [26 h]; Loader [28 h]; Dump Truck [28 h]; Bobcat [28 h]; Roller-Compactor (2~10 Ton) [28 h]; Roller-Compactor (25 Ton) [28 h]; Water Tanker [28 h] | 9,971.55 | 1.3.7.30 | CONS | CONS | ZONE-3 | REALM | ELEC |
|  | 2 | **Street Lighting Foundations,Poles and Lighting Fixures)** |  | 2017-03-04 | 2017-07-08 |  |  |  |  |  |  |  |  |  |  |  |
| CON-Z3-SL-LS-430 |  | Instalaltion of Concrete Foundations for 10m Poles | 8d | 2017-03-04 | 2017-03-13 | CON-Z3-SL-LS-380 | 168.6d | 0d | Common Labor / Helper [52 h]; Operator - Mobile Crane [26 h]; Driver - Flat Bed Trailer [26 h]; Mobile Crane ( 25-60 Ton) [28 h]; Flat Bed Trailer [28 h] | 13,960.17 | 1.3.7.30 | CONS | CONS | ZONE-3 | REALM | ELEC |
| CON-Z3-SL-LS-440 |  | Installation of Lighting Poles (10m) | 12d | 2017-03-13 | 2017-03-27 | CON-Z3-SL-LS-430 | 168.6d | 0d | Common Labor / Helper [52 h]; Operator - Mobile Crane [26 h]; Driver - Flat Bed Trailer [26 h]; Mobile Crane ( 25-60 Ton) [28 h]; Flat Bed Trailer [28 h] | 13,960.17 | 1.3.7.30 | CONS | CONS | ZONE-3 | REALM | ELEC |
| CON-Z3-SL-LS-460 |  | Instalaltion of Concrete Foundations for 8m Poles | 4d | 2017-03-13 | 2017-03-18 | CON-Z3-SL-LS-430 | 236.6d | 0d | Common Labor / Helper [52 h]; Operator - Mobile Crane [26 h]; Driver - Flat Bed Trailer [26 h]; Mobile Crane ( 25-60 Ton) [28 h]; Flat Bed Trailer [28 h] | 13,960.17 | 1.3.7.30 | CONS | CONS | ZONE-3 | REALM | ELEC |
| CON-Z3-SL-LS-470 |  | Installation of Lighting Poles (8m) | 4d | 2017-03-18 | 2017-03-22 | CON-Z3-SL-LS-460 | 244.6d | 76d | Common Labor / Helper [52 h]; Operator - Mobile Crane [26 h]; Driver - Flat Bed Trailer [26 h]; Mobile Crane ( 25-60 Ton) [28 h]; Flat Bed Trailer [28 h] | 13,960.17 | 1.3.7.30 | CONS | CONS | ZONE-3 | REALM | ELEC |
| CON-Z3-SL-LS-490 |  | Instalaltion of Concrete Foundations for Solar Bolard Lighting | 4d | 2017-03-18 | 2017-03-22 | CON-Z3-SL-LS-460 | 236.6d | 0d | Common Labor / Helper [52 h]; Operator - Mobile Crane [26 h]; Driver - Flat Bed Trailer [26 h]; Mobile Crane ( 25-60 Ton) [28 h]; Flat Bed Trailer [28 h] | 13,960.17 | 1.3.7.30 | CONS | CONS | ZONE-3 | REALM | ELEC |
| CON-Z3-SL-LS-510 |  | Instalaltion of Concrete Foundations for Solar Globe Lighting | 4d | 2017-03-22 | 2017-03-27 | CON-Z3-SL-LS-490 | 236.6d | 0d | Common Labor / Helper [52 h]; Operator - Mobile Crane [26 h]; Driver - Flat Bed Trailer [26 h]; Mobile Crane ( 25-60 Ton) [28 h]; Flat Bed Trailer [28 h] | 13,960.17 | 1.3.7.30 | CONS | CONS | ZONE-3 | REALM | ELEC |
| CON-Z3-SL-LS-540 |  | Instalaltion of Concrete Foundations for Walway Lightings | 4d | 2017-03-27 | 2017-04-01 | CON-Z3-SL-LS-510 | 236.6d | 68d | Common Labor / Helper [52 h]; Operator - Mobile Crane [26 h]; Driver - Flat Bed Trailer [26 h]; Mobile Crane ( 25-60 Ton) [28 h]; Flat Bed Trailer [28 h] | 13,960.17 | 1.3.7.30 | CONS | CONS | ZONE-3 | REALM | ELEC |
| CON-Z3-SL-LS-450 |  | Installation of Lighting Fixures for 10m Lighting Poles | 8d | 2017-06-19 | 2017-07-03 | CON-Z3-SL-LS-440 FS+72d | 168.6d | 0d | Electrician [104 h]; LC Crew [52 h]; Operator - Manlift (Boom Truck) [26 h]; Manlift (Boom Truck) [28 h] | 13,960.17 | 1.3.7.30 | CONS | CONS | ZONE-3 | REALM | ELEC |
| CON-Z3-SL-LS-480 |  | Installation of Lighting Fixures for 8m Lighting Poles | 4d | 2017-06-19 | 2017-06-24 | CON-Z3-SL-LS-470, CON-Z3-SL-LS-450 SS | 168.6d | 0d | Electrician [104 h]; LC Crew [52 h]; Operator - Manlift (Boom Truck) [26 h]; Manlift (Boom Truck) [28 h] | 13,960.17 | 1.3.7.30 | CONS | CONS | ZONE-3 | REALM | ELEC |
| CON-Z3-SL-LS-500 |  | Instalaltion of Solar Bolard Lightings | 4d | 2017-06-19 | 2017-06-24 | CON-Z3-SL-LS-480 SS, CON-Z3-SL-LS-490 | 168.6d | 0d | Electrician [52 h]; LC Crew [52 h] | 13,960.17 | 1.3.7.30 | CONS | CONS | ZONE-3 | REALM | ELEC |
| CON-Z3-SL-LS-520 |  | Instalaltion of Solar Globe Lightings | 4d | 2017-06-19 | 2017-06-24 | CON-Z3-SL-LS-510, CON-Z3-SL-LS-500 SS | 168.6d | 0d | Electrician [52 h]; LC Crew [52 h] | 13,960.17 | 1.3.7.30 | CONS | CONS | ZONE-3 | REALM | ELEC |
| CON-Z3-SL-LS-530 |  | Instalaltion of Walway Lightings | 4d | 2017-06-19 | 2017-06-24 | CON-Z3-SL-LS-520 SS, CON-Z3-SL-LS-540 | 168.6d | 0d | Electrician [52 h]; LC Crew [52 h] | 13,960.17 | 1.3.7.30 | CONS | CONS | ZONE-3 | REALM | ELEC |
| CON-Z3-SL-LS-550 |  | Termination and Grounding of LV Cables for Lighting Fixures | 8d | 2017-06-24 | 2017-07-08 | CON-Z3-SL-LS-360 SS, CON-Z3-SL-LS-530 | 168.6d | 0d | Electrician [52 h]; LC Crew [52 h] | 13,960.17 | 1.3.7.30 | CONS | CONS | ZONE-3 | REALM | ELEC |
| CON-Z3-SL-LS-560 |  | Installation of Solar Panels and Batteries | 4d | 2017-06-24 | 2017-07-03 | CON-Z3-SL-LS-370 SS, CON-Z3-SL-LS-530 | 176.6d | 8d | LC Crew [52 h]; Electrician [52 h] | 17,948.8 | 1.3.7.30 | CONS | CONS | ZONE-3 | REALM | ELEC |
|  | 4 | **Street Lighting Work for Area-4 (Public Realms Between Road-A and Road-5)** |  | 2017-03-04 | 2017-07-12 |  |  |  |  |  |  |  |  |  |  |  |
|  | 1 | **Street Lighting Cabling (LV)** |  | 2017-03-04 | 2017-04-13 |  |  |  |  |  |  |  |  |  |  |  |
| CON-Z3-SL-LS-570 |  | Excavation for Street Lighting Trench | 6.4d | 2017-03-04 | 2017-03-11 | CON-Z3-SL-LS-380 | 230.2d | 0d | Operator - Excavator [26 h] | 2,492.89 | 1.3.7.30 | CONS | CONS | ZONE-3 | REALM | ELEC |
| CON-Z3-SL-LS-580 |  | Sand bedding | 4d | 2017-03-11 | 2017-03-15 | CON-Z3-SL-LS-570 | 238.2d | 0d | Common Labor / Helper [104 h]; Operator - Loader [26 h]; Driver - Dump Truck [26 h]; Operator - Bobcat [26 h]; Operator - JCB [26 h]; Loader [28 h]; Dump Truck [28 h]; Bobcat [28 h]; JCB [28 h] | 1,661.93 | 1.3.7.30 | CONS | CONS | ZONE-3 | REALM | ELEC |
| CON-Z3-SL-LS-590 |  | Instalaltion of LV Cables | 4d | 2017-03-15 | 2017-03-20 | CON-Z3-SL-LS-580, PR-Z3-UT-EL-155-0080 | 238.2d | 0d | LC Crew [52 h] | 4,985.78 | 1.3.7.30 | CONS | CONS | ZONE-3 | REALM | ELEC |
| CON-Z3-SL-LS-600 |  | Sandfillling,Red Tiles and Warning Tape | 8d | 2017-03-20 | 2017-03-29 | CON-Z3-SL-LS-590 | 238.2d | 4.8d | Common Labor / Helper [78 h]; Block Mason [52 h]; Tiling Crew [52 h] | 4,154.81 | 1.3.7.30 | CONS | CONS | ZONE-3 | REALM | ELEC |
| CON-Z3-SL-LS-610 |  | Final Backfilling | 8d | 2017-04-04 | 2017-04-13 | CON-Z3-SL-LS-420, CON-Z3-SL-LS-600 | 233.4d | 0d | Common Labor / Helper [104 h]; Operator - Loader [26 h]; Driver - Dump Truck [26 h]; Operator - Bobcat [26 h]; Operator - Asphalt Compactor / Roller [26 h]; Operator - Roller-Compactor (2~10 Ton) [26 h]; Driver - Water Tanker [26 h]; Operator - JCB [26 h]; Loader [28 h]; Dump Truck [28 h]; Bobcat [28 h]; Roller-Compactor (2~10 Ton) [28 h]; Roller-Compactor (25 Ton) [28 h]; Water Tanker [28 h] | 3,323.85 | 1.3.7.30 | CONS | CONS | ZONE-3 | REALM | ELEC |

Notes:
- CON-Z3-SL-LS-380: Expenses: (New Expense Item) 7478.66
- CON-Z3-SL-LS-390: Expenses: (New Expense Item) 4985.78
- CON-Z3-SL-LS-400: Expenses: (New Expense Item) 14957.3
- CON-Z3-SL-LS-410: Expenses: (New Expense Item) 12464.4
- CON-Z3-SL-LS-420: Expenses: (New Expense Item) 9971.55
- CON-Z3-SL-LS-430: Expenses: (New Expense Item) 13960.2
- CON-Z3-SL-LS-440: Expenses: (New Expense Item) 13960.2
- CON-Z3-SL-LS-460: Expenses: (New Expense Item) 13960.2
- CON-Z3-SL-LS-470: Expenses: (New Expense Item) 13960.2
- CON-Z3-SL-LS-490: Expenses: (New Expense Item) 13960.2
- CON-Z3-SL-LS-510: Expenses: (New Expense Item) 13960.2
- CON-Z3-SL-LS-540: Expenses: (New Expense Item) 13960.2
- CON-Z3-SL-LS-450: Expenses: (New Expense Item) 13960.2
- CON-Z3-SL-LS-480: Expenses: (New Expense Item) 13960.2
- CON-Z3-SL-LS-500: Expenses: (New Expense Item) 13960.2
- CON-Z3-SL-LS-520: Expenses: (New Expense Item) 13960.2
- CON-Z3-SL-LS-530: Expenses: (New Expense Item) 13960.2
- CON-Z3-SL-LS-550: Expenses: (New Expense Item) 13960.2
- CON-Z3-SL-LS-560: Expenses: (New Expense Item) 17948.8
- CON-Z3-SL-LS-570: Expenses: (New Expense Item) 2492.89
- CON-Z3-SL-LS-580: Expenses: (New Expense Item) 1661.93
- CON-Z3-SL-LS-590: Expenses: (New Expense Item) 4985.78
- CON-Z3-SL-LS-600: Expenses: (New Expense Item) 4154.81
- CON-Z3-SL-LS-610: Expenses: (New Expense Item) 3323.85

| ID | WBS | Activity | Duration | Start | Finish | Predecessors | Total float | Free float | Resources | Cost | RPI_P2 - BOQ ITEMS | RPI_P2 - CONSTRUCTION | RPI_P2 - PHASE | RPI_P2 - ZONES | RPI_P2 - AREAS | RPI_P2 - DISCIPLINE / WORK TYPE |
| --- | --- | --- | --- | --- | --- | --- | --- | --- | --- | --- | --- | --- | --- | --- | --- | --- |
|  | 2 | **Street Lighting Foundations,Poles and Lighting Fixures)** |  | 2017-03-11 | 2017-07-12 |  |  |  |  |  |  |  |  |  |  |  |
| CON-Z3-SL-LS-620 |  | Instalaltion of Concrete Foundations for 10m Poles | 8d | 2017-03-11 | 2017-03-20 | CON-Z3-SL-LS-570 | 230.2d | 0d | Common Labor / Helper [52 h]; Operator - Mobile Crane [26 h]; Driver - Flat Bed Trailer [26 h]; Mobile Crane ( 25-60 Ton) [28 h]; Flat Bed Trailer [28 h] | 4,653.39 | 1.3.7.30 | CONS | CONS | ZONE-3 | REALM | ELEC |
| CON-Z3-SL-LS-630 |  | Installation of Lighting Poles (10m) | 12d | 2017-03-20 | 2017-04-03 | CON-Z3-SL-LS-620 | 234.2d | 0d | Common Labor / Helper [52 h]; Operator - Mobile Crane [26 h]; Driver - Flat Bed Trailer [26 h]; Mobile Crane ( 25-60 Ton) [28 h]; Flat Bed Trailer [28 h] | 4,653.39 | 1.3.7.30 | CONS | CONS | ZONE-3 | REALM | ELEC |
| CON-Z3-SL-LS-650 |  | Instalaltion of Concrete Foundations for 8m Poles | 4d | 2017-03-20 | 2017-03-25 | CON-Z3-SL-LS-620 | 230.2d | 0d | Common Labor / Helper [52 h]; Operator - Mobile Crane [26 h]; Driver - Flat Bed Trailer [26 h]; Mobile Crane ( 25-60 Ton) [28 h]; Flat Bed Trailer [28 h] | 4,653.39 | 1.3.7.30 | CONS | CONS | ZONE-3 | REALM | ELEC |
| CON-Z3-SL-LS-660 |  | Installation of Lighting Poles (8m) | 4d | 2017-03-25 | 2017-03-29 | CON-Z3-SL-LS-650 | 238.2d | 4d | Common Labor / Helper [52 h]; Operator - Mobile Crane [26 h]; Driver - Flat Bed Trailer [26 h]; Mobile Crane ( 25-60 Ton) [28 h]; Flat Bed Trailer [28 h] | 4,653.39 | 1.3.7.30 | CONS | CONS | ZONE-3 | REALM | ELEC |
| CON-Z3-SL-LS-680 |  | Instalaltion of Concrete Foundations for Solar Bolard Lighting | 4d | 2017-03-25 | 2017-03-29 | CON-Z3-SL-LS-650 | 230.2d | 0d | Common Labor / Helper [52 h]; Operator - Mobile Crane [26 h]; Driver - Flat Bed Trailer [26 h]; Mobile Crane ( 25-60 Ton) [28 h]; Flat Bed Trailer [28 h] | 4,653.39 | 1.3.7.30 | CONS | CONS | ZONE-3 | REALM | ELEC |
| CON-Z3-SL-LS-700 |  | Instalaltion of Concrete Foundations for Solar Globe Lighting | 4d | 2017-03-29 | 2017-04-03 | CON-Z3-SL-LS-680 | 230.2d | 0d | Common Labor / Helper [52 h]; Operator - Mobile Crane [26 h]; Driver - Flat Bed Trailer [26 h]; Mobile Crane ( 25-60 Ton) [28 h]; Flat Bed Trailer [28 h] | 4,653.39 | 1.3.7.30 | CONS | CONS | ZONE-3 | REALM | ELEC |
| CON-Z3-SL-LS-640 |  | Installation of Lighting Fixures for 10m Lighting Poles | 8d | 2017-04-03 | 2017-04-12 | CON-Z3-SL-LS-630 | 234.2d | 0d | Electrician [104 h]; LC Crew [52 h]; Operator - Manlift (Boom Truck) [26 h]; Manlift (Boom Truck) [28 h] | 4,653.39 | 1.3.7.30 | CONS | CONS | ZONE-3 | REALM | ELEC |
| CON-Z3-SL-LS-670 |  | Installation of Lighting Fixures for 8m Lighting Poles | 4d | 2017-04-03 | 2017-04-08 | CON-Z3-SL-LS-640 SS, CON-Z3-SL-LS-660 | 234.2d | 0d | Electrician [104 h]; LC Crew [52 h]; Operator - Manlift (Boom Truck) [26 h]; Manlift (Boom Truck) [28 h] | 4,653.39 | 1.3.7.30 | CONS | CONS | ZONE-3 | REALM | ELEC |
| CON-Z3-SL-LS-690 |  | Instalaltion of Solar Bolard Lightings | 4d | 2017-04-03 | 2017-04-08 | PR-Z3-CW-MS-30-0080, CON-Z3-SL-LS-670 SS, CON-Z3-SL-LS-680 | 234.2d | 0.8d | Electrician [52 h]; LC Crew [52 h] | 4,653.39 | 1.3.7.30 | CONS | CONS | ZONE-3 | REALM | ELEC |
| CON-Z3-SL-LS-730 |  | Instalaltion of Concrete Foundations for Walway Lightings | 4d | 2017-04-03 | 2017-04-08 | CON-Z3-SL-LS-700 | 230.2d | 0d | Common Labor / Helper [52 h]; Operator - Mobile Crane [26 h]; Driver - Flat Bed Trailer [26 h]; Mobile Crane ( 25-60 Ton) [28 h]; Flat Bed Trailer [28 h] | 4,653.39 | 1.3.7.30 | CONS | CONS | ZONE-3 | REALM | ELEC |
| CON-Z3-SL-LS-710 |  | Instalaltion of Solar Globe Lightings | 4d | 2017-04-04 | 2017-04-09 | CON-Z3-SL-LS-610 SS, CON-Z3-SL-LS-700, CON-Z3-SL-LS-690 SS | 233.4d | 3.2d | Electrician [52 h]; LC Crew [52 h] | 4,653.39 | 1.3.7.30 | CONS | CONS | ZONE-3 | REALM | ELEC |
| CON-Z3-SL-LS-720 |  | Instalaltion of Walway Lightings | 4d | 2017-04-08 | 2017-04-12 | CON-Z3-SL-LS-730, CON-Z3-SL-LS-710 SS | 230.2d | 61.6d | Electrician [52 h]; LC Crew [52 h] | 4,653.39 | 1.3.7.30 | CONS | CONS | ZONE-3 | REALM | ELEC |
| CON-Z3-SL-LS-740 |  | Termination and Grounding of LV Cables for Lighting Fixures | 8d | 2017-06-24 | 2017-07-08 | CON-Z3-SL-LS-550 SS, CON-Z3-SL-LS-720 | 168.6d | 0d | Electrician [52 h]; LC Crew [52 h] | 4,653.39 | 1.3.7.30 | CONS | CONS | ZONE-3 | REALM | ELEC |
| CON-Z3-SL-LS-750 |  | Installation of Solar Panels and Batteries | 4d | 2017-07-08 | 2017-07-12 | CON-Z3-SL-LS-740, CON-Z3-SL-LS-560 SS, CON-Z3-SL-LS-720 | 168.6d | 47.4d | Electrician [52 h]; LC Crew [52 h] | 5,982.93 | 1.3.7.30 | CONS | CONS | ZONE-3 | REALM | ELEC |
|  | 2 | **Hard Landscaping in Public Realms (Walkways and Pedestrains)** |  | 2016-12-07 | 2017-05-31 |  |  |  |  |  |  |  |  |  |  |  |
|  | 1 | **Walkways and Pedestrains for Area-1 (Public Realms Between Road-A and Road-4)** |  | 2016-12-07 | 2017-05-18 |  |  |  |  |  |  |  |  |  |  |  |
|  | 1 | **Right Line** |  | 2016-12-07 | 2017-05-18 |  |  |  |  |  |  |  |  |  |  |  |
| CON-Z3-HRD-LS-0010 |  | Cleaning,Bedding and Surface Preparation | 4d | 2016-12-07 | 2016-12-12 | CON-Z3-SF-LS-GE-0010, PR-Z3-LW-LS-105-0080 | 232.6d | 0d | Common Labor / Helper [104 h]; Operator - Roller-Compactor (2~10 Ton) [80 h]; Operator - JCB [80 h]; Roller-Compactor (2~10 Ton) [112 h]; JCB [112 h] | 11,633.48 | 1.3.7.30 | CONS | CONS | ZONE-3 | REALM | HARDSCAPE |
| CON-Z3-HRD-LS-0020 |  | Installation of Wire Mesh and Concrete Work | 8d | 2016-12-12 | 2016-12-21 | CON-Z3-HRD-LS-0010, PR-Z3-LW-LS-111-0080, PR-Z3-LW-LS-104-0080 | 283.8d | 107d | Steel Fixer [78 h]; Shuttering Carpenter [78 h]; Concrete Mason [78 h]; Common Labor / Helper [78 h]; Driver - Conc. Transit Mixers [26 h]; Operator - Concrete Pump [26 h] | 29,083.7 | 1.3.7.30 | CONS | CONS | ZONE-3 | REALM | HARDSCAPE |
| CON-Z3-HRD-LS-0030 |  | Installation of Tiles (Paving Blocks) | 12d | 2017-04-25 | 2017-05-09 | PR-Z3-LW-LS-112-0080, PR-Z3-LW-LS-109-0080, CON-Z3-HRD-LS-0020 | 176.8d | 0d | Common Labor / Helper [104 h]; Block Mason [52 h]; Tiling Crew [52 h] | 11,633.48 | 1.3.7.30 | CONS | CONS | ZONE-3 | REALM | HARDSCAPE |
| CON-Z3-HRD-LS-0040 |  | Installation of Hand Rails | 8d | 2017-05-09 | 2017-05-18 | PR-Z3-LW-LS-113-0080, PR-Z3-LW-LS-115-0080, PR-Z3-LW-LS-117-0080, CON-Z3-HRD-LS-0030 | 176.8d | 0d | Common Labor / Helper [78 h] | 5,816.74 | 1.3.7.30 | CONS | CONS | ZONE-3 | REALM | HARDSCAPE |
|  | 2 | **Left Line** |  | 2016-12-12 | 2017-05-18 |  |  |  |  |  |  |  |  |  |  |  |
| CON-Z3-HRD-LS-40 |  | Cleaning,Bedding and Surface Preparation | 4d | 2016-12-12 | 2016-12-17 | CON-Z3-HRD-LS-0010 | 232.6d | 0d | Common Labor / Helper [104 h]; Operator - Roller-Compactor (2~10 Ton) [26 h]; Operator - JCB [80 h]; Roller-Compactor (2~10 Ton) [28 h]; JCB [112 h] | 11,633.48 | 1.3.7.30 | CONS | CONS | ZONE-3 | REALM | HARDSCAPE |
| CON-Z3-HRD-LS-50 |  | Installation of Wire Mesh and Concrete Work | 8d | 2016-12-17 | 2016-12-26 | CON-Z3-HRD-LS-40 | 279.8d | 0d | Steel Fixer [78 h]; Shuttering Carpenter [78 h]; Concrete Mason [78 h]; Common Labor / Helper [78 h]; Driver - Conc. Transit Mixers [26 h]; Operator - Concrete Pump [26 h] | 29,083.7 | 1.3.7.30 | CONS | CONS | ZONE-3 | REALM | HARDSCAPE |
| CON-Z3-HRD-LS-60 |  | Installation of Tiles (Paving Blocks) | 12d | 2016-12-26 | 2017-01-09 | CON-Z3-HRD-LS-50 | 279.8d | 103d | Common Labor / Helper [104 h]; Block Mason [52 h]; Tiling Crew [52 h] | 11,633.48 | 1.3.7.30 | CONS | CONS | ZONE-3 | REALM | HARDSCAPE |
| CON-Z3-HRD-LS-70 |  | Installation of Hand Rails | 8d | 2017-05-09 | 2017-05-18 | CON-Z3-HRD-LS-0040 SS, CON-Z3-HRD-LS-60 | 176.8d | 10.6d | Common Labor / Helper [78 h] | 5,816.74 | 1.3.7.30 | CONS | CONS | ZONE-3 | REALM | HARDSCAPE |

Notes:
- CON-Z3-SL-LS-620: Expenses: (New Expense Item) 4653.39
- CON-Z3-SL-LS-630: Expenses: (New Expense Item) 4653.39
- CON-Z3-SL-LS-650: Expenses: (New Expense Item) 4653.39
- CON-Z3-SL-LS-660: Expenses: (New Expense Item) 4653.39
- CON-Z3-SL-LS-680: Expenses: (New Expense Item) 4653.39
- CON-Z3-SL-LS-700: Expenses: (New Expense Item) 4653.39
- CON-Z3-SL-LS-640: Expenses: (New Expense Item) 4653.39
- CON-Z3-SL-LS-670: Expenses: (New Expense Item) 4653.39
- CON-Z3-SL-LS-690: Expenses: (New Expense Item) 4653.39
- CON-Z3-SL-LS-730: Expenses: (New Expense Item) 4653.39
- CON-Z3-SL-LS-710: Expenses: (New Expense Item) 4653.39
- CON-Z3-SL-LS-720: Expenses: (New Expense Item) 4653.39
- CON-Z3-SL-LS-740: Expenses: (New Expense Item) 4653.39
- CON-Z3-SL-LS-750: Expenses: (New Expense Item) 5982.93
- CON-Z3-HRD-LS-0010: Expenses: (New Expense Item) 11633.5
- CON-Z3-HRD-LS-0020: Expenses: (New Expense Item) 29083.7
- CON-Z3-HRD-LS-0030: Expenses: (New Expense Item) 11633.5
- CON-Z3-HRD-LS-0040: Expenses: (New Expense Item) 5816.74
- CON-Z3-HRD-LS-40: Expenses: (New Expense Item) 11633.5
- CON-Z3-HRD-LS-50: Expenses: (New Expense Item) 29083.7
- CON-Z3-HRD-LS-60: Expenses: (New Expense Item) 11633.5
- CON-Z3-HRD-LS-70: Expenses: (New Expense Item) 5816.74

| ID | WBS | Activity | Duration | Start | Finish | Predecessors | Total float | Free float | Resources | Cost | RPI_P2 - BOQ ITEMS | RPI_P2 - CONSTRUCTION | RPI_P2 - PHASE | RPI_P2 - ZONES | RPI_P2 - AREAS | RPI_P2 - DISCIPLINE / WORK TYPE |
| --- | --- | --- | --- | --- | --- | --- | --- | --- | --- | --- | --- | --- | --- | --- | --- | --- |
|  | 3 | **Center Line** |  | 2016-12-17 | 2017-05-13 |  |  |  |  |  |  |  |  |  |  |  |
| CON-Z3-HRD-LS-80 |  | Cleaning,Bedding and Surface Preparation | 4d | 2016-12-17 | 2016-12-21 | CON-Z3-HRD-LS-40 | 232.6d | 0d | Common Labor / Helper [104 h]; Operator - Roller-Compactor (2~10 Ton) [80 h]; Operator - JCB [80 h]; Roller-Compactor (2~10 Ton) [112 h]; JCB [112 h] | 9,971.55 | 1.3.7.30 | CONS | CONS | ZONE-3 | REALM | HARDSCAPE |
| CON-Z3-HRD-LS-90 |  | Installation of Curb and Gutter | 8d | 2017-04-19 | 2017-04-29 | CON-Z3-HRD-LS-80, PR-Z3-CW-CW-21-0080, PR-Z3-LW-LS-109-170 | 166.2d | 0d | Steel Fixer [78 h]; Shuttering Carpenter [78 h]; Concrete Mason [78 h]; Common Labor / Helper [52 h] | 14,957.33 | 1.3.7.30 | CONS | CONS | ZONE-3 | REALM | HARDSCAPE |
| CON-Z3-HRD-LS-100 |  | Installation of Wire Mesh and Concrete Work | 12d | 2017-04-29 | 2017-05-13 | CON-Z3-HRD-LS-50 SS, CON-Z3-HRD-LS-90 | 166.2d | 0d | Steel Fixer [78 h]; Shuttering Carpenter [78 h]; Concrete Mason [78 h]; Common Labor / Helper [78 h]; Driver - Conc. Transit Mixers [26 h]; Operator - Concrete Pump [26 h] | 24,928.88 | 1.3.7.30 | CONS | CONS | ZONE-3 | REALM | HARDSCAPE |
|  | 4 | **Walkways and Pedestrains for Area-2 (Public Realms Between Road-4 and Road-B)** |  | 2016-12-21 | 2017-05-31 |  |  |  |  |  |  |  |  |  |  |  |
|  | 1 | **Right Line** |  | 2016-12-21 | 2017-05-31 |  |  |  |  |  |  |  |  |  |  |  |
| CON-Z3-HRD-LS-110 |  | Cleaning,Bedding and Surface Preparation | 4d | 2016-12-21 | 2016-12-26 | CON-Z3-HRD-LS-80 | 232.6d | 0d | Common Labor / Helper [104 h]; Operator - Roller-Compactor (2~10 Ton) [80 h]; Operator - JCB [80 h]; Roller-Compactor (2~10 Ton) [112 h]; JCB [112 h] | 11,633.48 | 1.3.7.30 | CONS | CONS | ZONE-3 | REALM | HARDSCAPE |
| CON-Z3-HRD-LS-120 |  | Installation of Wire Mesh and Concrete Work | 8d | 2017-04-29 | 2017-05-08 | CON-Z3-HRD-LS-110, CON-Z3-HRD-LS-100 SS | 166.2d | 0d | Steel Fixer [78 h]; Shuttering Carpenter [78 h]; Concrete Mason [78 h]; Common Labor / Helper [78 h]; Driver - Conc. Transit Mixers [26 h]; Operator - Concrete Pump [26 h] | 29,083.7 | 1.3.7.30 | CONS | CONS | ZONE-3 | REALM | HARDSCAPE |
| CON-Z3-HRD-LS-130 |  | Installation of Tiles (Paving Blocks) | 12d | 2017-05-08 | 2017-05-22 | CON-Z3-HRD-LS-120 | 166.2d | 0d | Common Labor / Helper [104 h]; Block Mason [52 h]; Tiling Crew [52 h] | 11,633.48 | 1.3.7.30 | CONS | CONS | ZONE-3 | REALM | HARDSCAPE |
| CON-Z3-HRD-LS-140 |  | Installation of Hand Rails | 8d | 2017-05-22 | 2017-05-31 | CON-Z3-HRD-LS-70 SS, CON-Z3-HRD-LS-130 | 166.2d | 0d | Common Labor / Helper [78 h] | 5,816.74 | 1.3.7.30 | CONS | CONS | ZONE-3 | REALM | HARDSCAPE |
|  | 2 | **Left Line** |  | 2016-12-26 | 2017-05-31 |  |  |  |  |  |  |  |  |  |  |  |
| CON-Z3-HRD-LS-150 |  | Cleaning,Bedding and Surface Preparation | 4d | 2016-12-26 | 2016-12-31 | CON-Z3-HRD-LS-110 | 232.6d | 0d | Common Labor / Helper [104 h]; Operator - Roller-Compactor (2~10 Ton) [80 h]; Operator - JCB [80 h]; Roller-Compactor (2~10 Ton) [112 h]; JCB [112 h] | 11,633.48 | 1.3.7.30 | CONS | CONS | ZONE-3 | REALM | HARDSCAPE |
| CON-Z3-HRD-LS-160 |  | Installation of Wire Mesh and Concrete Work | 8d | 2016-12-31 | 2017-01-09 | CON-Z3-HRD-LS-150 | 267.8d | 0d | Steel Fixer [78 h]; Shuttering Carpenter [78 h]; Concrete Mason [78 h]; Common Labor / Helper [78 h]; Driver - Conc. Transit Mixers [26 h]; Operator - Concrete Pump [26 h] | 29,083.7 | 1.3.7.30 | CONS | CONS | ZONE-3 | REALM | HARDSCAPE |
| CON-Z3-HRD-LS-170 |  | Installation of Tiles (Paving Blocks) | 12d | 2017-01-09 | 2017-01-23 | CON-Z3-HRD-LS-160 | 267.8d | 101.6d | Common Labor / Helper [104 h]; Block Mason [52 h]; Tiling Crew [52 h] | 11,633.48 | 1.3.7.30 | CONS | CONS | ZONE-3 | REALM | HARDSCAPE |
| CON-Z3-HRD-LS-180 |  | Installation of Hand Rails | 8d | 2017-05-22 | 2017-05-31 | CON-Z3-HRD-LS-170, CON-Z3-HRD-LS-140 SS | 166.2d | 0d | Common Labor / Helper [78 h] | 5,816.74 | 1.3.7.30 | CONS | CONS | ZONE-3 | REALM | HARDSCAPE |
|  | 3 | **Center Line** |  | 2016-12-31 | 2017-01-28 |  |  |  |  |  |  |  |  |  |  |  |
| CON-Z3-HRD-LS-190 |  | Cleaning,Bedding and Surface Preparation | 4d | 2016-12-31 | 2017-01-04 | CON-Z3-HRD-LS-150 | 232.6d | 0d | Common Labor / Helper [104 h]; Operator - Roller-Compactor (2~10 Ton) [26 h]; Operator - JCB [26 h]; Roller-Compactor (2~10 Ton) [28 h]; JCB [28 h] | 24,928.88 | 1.3.7.30 | CONS | CONS | ZONE-3 | REALM | HARDSCAPE |
| CON-Z3-HRD-LS-200 |  | Installation of Curb and Gutter | 8d | 2017-01-04 | 2017-01-14 | CON-Z3-HRD-LS-190 | 255.8d | 0d | Steel Fixer [78 h]; Shuttering Carpenter [78 h]; Concrete Mason [78 h]; Common Labor / Helper [52 h] | 9,971.55 | 1.3.7.30 | CONS | CONS | ZONE-3 | REALM | HARDSCAPE |
| CON-Z3-HRD-LS-210 |  | Installation of Wire Mesh and Concrete Work | 12d | 2017-01-14 | 2017-01-28 | CON-Z3-HRD-LS-200, CON-Z3-HRD-LS-160 SS | 255.8d | 0d | Steel Fixer [78 h]; Shuttering Carpenter [78 h]; Concrete Mason [78 h]; Common Labor / Helper [78 h]; Driver - Conc. Transit Mixers [26 h]; Operator - Concrete Pump [26 h] | 14,957.33 | 1.3.7.30 | CONS | CONS | ZONE-3 | REALM | HARDSCAPE |
|  | 2 | **Walkways and Pedestrains for Area-3 (Public Realms Between Road-B and Road-A)** |  | 2017-01-04 | 2017-05-31 |  |  |  |  |  |  |  |  |  |  |  |
|  | 1 | **Right Line** |  | 2017-01-04 | 2017-05-31 |  |  |  |  |  |  |  |  |  |  |  |
| CON-Z3-HRD-LS-220 |  | Cleaning,Bedding and Surface Preparation | 4d | 2017-01-04 | 2017-01-09 | CON-Z3-HRD-LS-190 | 232.6d | 0d | Common Labor / Helper [104 h]; Operator - Roller-Compactor (2~10 Ton) [26 h]; Operator - JCB [26 h]; Roller-Compactor (2~10 Ton) [28 h]; JCB [28 h] | 11,633.48 | 1.3.7.30 | CONS | CONS | ZONE-3 | REALM | HARDSCAPE |
| CON-Z3-HRD-LS-230 |  | Installation of Wire Mesh and Concrete Work | 8d | 2017-01-14 | 2017-01-23 | CON-Z3-HRD-LS-210 SS, CON-Z3-HRD-LS-220 | 255.8d | 0d | Steel Fixer [78 h]; Shuttering Carpenter [78 h]; Concrete Mason [78 h]; Common Labor / Helper [78 h]; Driver - Conc. Transit Mixers [26 h]; Operator - Concrete Pump [26 h] | 29,083.7 | 1.3.7.30 | CONS | CONS | ZONE-3 | REALM | HARDSCAPE |
| CON-Z3-HRD-LS-240 |  | Installation of Tiles (Paving Blocks) | 12d | 2017-01-23 | 2017-02-06 | CON-Z3-HRD-LS-230 | 255.8d | 89.6d | Common Labor / Helper [104 h]; Block Mason [52 h]; Tiling Crew [52 h] | 11,633.48 | 1.3.7.30 | CONS | CONS | ZONE-3 | REALM | HARDSCAPE |
| CON-Z3-HRD-LS-250 |  | Installation of Hand Rails | 8d | 2017-05-22 | 2017-05-31 | CON-Z3-HRD-LS-240, CON-Z3-HRD-LS-180 SS | 166.2d | 0d | Common Labor / Helper [78 h] | 5,816.74 | 1.3.7.30 | CONS | CONS | ZONE-3 | REALM | HARDSCAPE |

Notes:
- CON-Z3-HRD-LS-80: Expenses: (New Expense Item) 9971.55
- CON-Z3-HRD-LS-90: Expenses: (New Expense Item) 14957.3
- CON-Z3-HRD-LS-100: Expenses: (New Expense Item) 24928.9
- CON-Z3-HRD-LS-110: Expenses: (New Expense Item) 11633.5
- CON-Z3-HRD-LS-120: Expenses: (New Expense Item) 29083.7
- CON-Z3-HRD-LS-130: Expenses: (New Expense Item) 11633.5
- CON-Z3-HRD-LS-140: Expenses: (New Expense Item) 5816.74
- CON-Z3-HRD-LS-150: Expenses: (New Expense Item) 11633.5
- CON-Z3-HRD-LS-160: Expenses: (New Expense Item) 29083.7
- CON-Z3-HRD-LS-170: Expenses: (New Expense Item) 11633.5
- CON-Z3-HRD-LS-180: Expenses: (New Expense Item) 5816.74
- CON-Z3-HRD-LS-190: Expenses: (New Expense Item) 24928.9
- CON-Z3-HRD-LS-200: Expenses: (New Expense Item) 9971.55
- CON-Z3-HRD-LS-210: Expenses: (New Expense Item) 14957.3
- CON-Z3-HRD-LS-220: Expenses: (New Expense Item) 11633.5
- CON-Z3-HRD-LS-230: Expenses: (New Expense Item) 29083.7
- CON-Z3-HRD-LS-240: Expenses: (New Expense Item) 11633.5
- CON-Z3-HRD-LS-250: Expenses: (New Expense Item) 5816.74

| ID | WBS | Activity | Duration | Start | Finish | Predecessors | Total float | Free float | Resources | Cost | RPI_P2 - BOQ ITEMS | RPI_P2 - CONSTRUCTION | RPI_P2 - PHASE | RPI_P2 - ZONES | RPI_P2 - AREAS | RPI_P2 - DISCIPLINE / WORK TYPE |
| --- | --- | --- | --- | --- | --- | --- | --- | --- | --- | --- | --- | --- | --- | --- | --- | --- |
|  | 2 | **Left Line** |  | 2017-01-09 | 2017-05-31 |  |  |  |  |  |  |  |  |  |  |  |
| CON-Z3-HRD-LS-260 |  | Cleaning,Bedding and Surface Preparation | 4d | 2017-01-09 | 2017-01-14 | CON-Z3-HRD-LS-220 | 232.6d | 0d | Common Labor / Helper [104 h]; Operator - Roller-Compactor (2~10 Ton) [26 h]; Operator - JCB [26 h]; Roller-Compactor (2~10 Ton) [28 h]; JCB [28 h] | 11,633.48 | 1.3.7.30 | CONS | CONS | ZONE-3 | REALM | HARDSCAPE |
| CON-Z3-HRD-LS-270 |  | Installation of Wire Mesh and Concrete Work | 8d | 2017-01-14 | 2017-01-23 | CON-Z3-HRD-LS-260 | 255.8d | 0d | Steel Fixer [78 h]; Shuttering Carpenter [78 h]; Concrete Mason [78 h]; Common Labor / Helper [78 h]; Driver - Conc. Transit Mixers [26 h]; Operator - Concrete Pump [26 h] | 29,083.7 | 1.3.7.30 | CONS | CONS | ZONE-3 | REALM | HARDSCAPE |
| CON-Z3-HRD-LS-280 |  | Installation of Tiles (Paving Blocks) | 12d | 2017-01-23 | 2017-02-06 | CON-Z3-HRD-LS-270 | 255.8d | 89.6d | Common Labor / Helper [104 h]; Block Mason [52 h]; Tiling Crew [52 h] | 11,633.48 | 1.3.7.30 | CONS | CONS | ZONE-3 | REALM | HARDSCAPE |
| CON-Z3-HRD-LS-290 |  | Installation of Hand Rails | 8d | 2017-05-22 | 2017-05-31 | CON-Z3-HRD-LS-250 SS, CON-Z3-HRD-LS-280 | 166.2d | 0d | Common Labor / Helper [78 h] | 5,816.74 | 1.3.7.30 | CONS | CONS | ZONE-3 | REALM | HARDSCAPE |
|  | 3 | **Center Line** |  | 2017-01-14 | 2017-02-11 |  |  |  |  |  |  |  |  |  |  |  |
| CON-Z3-HRD-LS-300 |  | Cleaning,Bedding and Surface Preparation | 4d | 2017-01-14 | 2017-01-18 | CON-Z3-HRD-LS-260 | 232.6d | 0d | Common Labor / Helper [104 h]; Operator - Roller-Compactor (2~10 Ton) [26 h]; Operator - JCB [26 h]; Roller-Compactor (2~10 Ton) [28 h]; JCB [28 h] | 24,928.88 | 1.3.7.30 | CONS | CONS | ZONE-3 | REALM | HARDSCAPE |
| CON-Z3-HRD-LS-310 |  | Installation of Curb and Gutter | 8d | 2017-01-18 | 2017-01-28 | CON-Z3-HRD-LS-300 | 249.4d | 0d | Steel Fixer [78 h]; Shuttering Carpenter [78 h]; Concrete Mason [78 h]; Common Labor / Helper [52 h] | 9,971.55 | 1.3.7.30 | CONS | CONS | ZONE-3 | REALM | HARDSCAPE |
| CON-Z3-HRD-LS-320 |  | Installation of Wire Mesh and Concrete Work | 12d | 2017-01-28 | 2017-02-11 | CON-Z3-HRD-LS-270 SS, CON-Z3-HRD-LS-310 | 249.4d | 0d | Steel Fixer [78 h]; Shuttering Carpenter [78 h]; Concrete Mason [78 h]; Common Labor / Helper [78 h]; Driver - Conc. Transit Mixers [26 h]; Operator - Concrete Pump [26 h] | 14,957.33 | 1.3.7.30 | CONS | CONS | ZONE-3 | REALM | HARDSCAPE |
|  | 3 | **Walkways and Pedestrains for Area-3 (Public Realms Between Road-A and Road-5)** |  | 2017-01-18 | 2017-05-31 |  |  |  |  |  |  |  |  |  |  |  |
|  | 1 | **Right Line** |  | 2017-01-18 | 2017-05-29 |  |  |  |  |  |  |  |  |  |  |  |
| CON-Z3-HRD-LS-330 |  | Cleaning,Bedding and Surface Preparation | 2.4d | 2017-01-18 | 2017-01-22 | CON-Z3-HRD-LS-300 | 232.6d | 0d | Common Labor / Helper [104 h]; Operator - Roller-Compactor (2~10 Ton) [26 h]; Operator - JCB [26 h]; Roller-Compactor (2~10 Ton) [28 h]; JCB [28 h] | 3,877.83 | 1.3.7.30 | CONS | CONS | ZONE-3 | REALM | HARDSCAPE |
| CON-Z3-HRD-LS-340 |  | Installation of Wire Mesh and Concrete Work | 6.4d | 2017-01-28 | 2017-02-05 | CON-Z3-HRD-LS-320 SS, CON-Z3-HRD-LS-330 | 249.4d | 0d | Steel Fixer [78 h]; Shuttering Carpenter [78 h]; Concrete Mason [78 h]; Common Labor / Helper [78 h]; Driver - Conc. Transit Mixers [26 h]; Operator - Concrete Pump [26 h] | 9,694.57 | 1.3.7.30 | CONS | CONS | ZONE-3 | REALM | HARDSCAPE |
| CON-Z3-HRD-LS-350 |  | Installation of Tiles (Paving Blocks) | 8d | 2017-02-05 | 2017-02-14 | CON-Z3-HRD-LS-340 | 249.4d | 83.2d | Common Labor / Helper [104 h]; Tiling Crew [52 h]; Block Mason [52 h] | 3,877.83 | 1.3.7.30 | CONS | CONS | ZONE-3 | REALM | HARDSCAPE |
| CON-Z3-HRD-LS-360 |  | Installation of Hand Rails | 6.4d | 2017-05-22 | 2017-05-29 | CON-Z3-HRD-LS-290 SS, CON-Z3-HRD-LS-350 | 166.2d | 0d | Common Labor / Helper [78 h] | 1,938.91 | 1.3.7.30 | CONS | CONS | ZONE-3 | REALM | HARDSCAPE |
|  | 2 | **Left Line** |  | 2017-01-22 | 2017-05-29 |  |  |  |  |  |  |  |  |  |  |  |
| CON-Z3-HRD-LS-370 |  | Cleaning,Bedding and Surface Preparation | 2.4d | 2017-01-22 | 2017-01-24 | CON-Z3-HRD-LS-330 | 232.6d | 0d | Roller-Compactor (2~10 Ton) [28 h]; JCB [28 h]; Common Labor / Helper [104 h]; Operator - Roller-Compactor (2~10 Ton) [26 h]; Operator - JCB [26 h] | 3,877.83 | 1.3.7.30 | CONS | CONS | ZONE-3 | REALM | HARDSCAPE |
| CON-Z3-HRD-LS-380 |  | Installation of Wire Mesh and Concrete Work | 6.4d | 2017-01-24 | 2017-01-31 | CON-Z3-HRD-LS-370 | 252.6d | 0d | Shuttering Carpenter [78 h]; Concrete Mason [78 h]; Common Labor / Helper [78 h]; Driver - Conc. Transit Mixers [26 h]; Operator - Concrete Pump [26 h]; Steel Fixer [78 h] | 9,694.57 | 1.3.7.30 | CONS | CONS | ZONE-3 | REALM | HARDSCAPE |
| CON-Z3-HRD-LS-390 |  | Installation of Tiles (Paving Blocks) | 8d | 2017-02-01 | 2017-02-09 | CON-Z3-HRD-LS-380 | 252.6d | 86.4d | Common Labor / Helper [78 h]; Block Mason [52 h]; Tiling Crew [52 h] | 3,877.83 | 1.3.7.30 | CONS | CONS | ZONE-3 | REALM | HARDSCAPE |
| CON-Z3-HRD-LS-400 |  | Installation of Hand Rails | 6.4d | 2017-05-22 | 2017-05-29 | CON-Z3-HRD-LS-390, CON-Z3-HRD-LS-360 SS | 166.2d | 0d | Common Labor / Helper [78 h] | 1,938.91 | 1.3.7.30 | CONS | CONS | ZONE-3 | REALM | HARDSCAPE |
|  | 3 | **Center Line** |  | 2017-01-24 | 2017-05-31 |  |  |  |  |  |  |  |  |  |  |  |
| CON-Z3-HRD-LS-410 |  | Cleaning,Bedding and Surface Preparation | 2.4d | 2017-01-24 | 2017-01-26 | CON-Z3-HRD-LS-370 | 232.6d | 0d | Common Labor / Helper [104 h]; Operator - Roller-Compactor (2~10 Ton) [26 h]; Operator - JCB [26 h]; Roller-Compactor (2~10 Ton) [28 h]; JCB [28 h] | 8,309.63 | 1.3.7.30 | CONS | CONS | ZONE-3 | REALM | HARDSCAPE |
| CON-Z3-HRD-LS-420 |  | Installation of Curb and Gutter | 6.4d | 2017-01-28 | 2017-02-04 | CON-Z3-HRD-LS-410 | 258.2d | 92d | Steel Fixer [78 h]; Shuttering Carpenter [78 h]; Concrete Mason [78 h]; Common Labor / Helper [52 h] | 3,323.85 | 1.3.7.30 | CONS | CONS | ZONE-3 | REALM | HARDSCAPE |
| CON-Z3-HRD-LS-430 |  | Installation of Wire Mesh and Concrete Work | 8d | 2017-05-22 | 2017-05-31 | CON-Z3-HRD-LS-400 SS, CON-Z3-HRD-LS-420, CON-Z3-HRD-LS-380 SS | 166.2d | 51.4d | Steel Fixer [78 h]; Shuttering Carpenter [78 h]; Concrete Mason [78 h]; Common Labor / Helper [78 h]; Driver - Conc. Transit Mixers [26 h]; Operator - Concrete Pump [26 h] | 4,985.78 | 1.3.7.30 | CONS | CONS | ZONE-3 | REALM | HARDSCAPE |

Notes:
- CON-Z3-HRD-LS-260: Expenses: (New Expense Item) 11633.5
- CON-Z3-HRD-LS-270: Expenses: (New Expense Item) 29083.7
- CON-Z3-HRD-LS-280: Expenses: (New Expense Item) 11633.5
- CON-Z3-HRD-LS-290: Expenses: (New Expense Item) 5816.74
- CON-Z3-HRD-LS-300: Expenses: (New Expense Item) 24928.9
- CON-Z3-HRD-LS-310: Expenses: (New Expense Item) 9971.55
- CON-Z3-HRD-LS-320: Expenses: (New Expense Item) 14957.3
- CON-Z3-HRD-LS-330: Expenses: (New Expense Item) 3877.83
- CON-Z3-HRD-LS-340: Expenses: (New Expense Item) 9694.57
- CON-Z3-HRD-LS-350: Expenses: (New Expense Item) 3877.83
- CON-Z3-HRD-LS-360: Expenses: (New Expense Item) 1938.91
- CON-Z3-HRD-LS-370: Expenses: (New Expense Item) 3877.83
- CON-Z3-HRD-LS-380: Expenses: (New Expense Item) 9694.57
- CON-Z3-HRD-LS-390: Expenses: (New Expense Item) 3877.83
- CON-Z3-HRD-LS-400: Expenses: (New Expense Item) 1938.91
- CON-Z3-HRD-LS-410: Expenses: (New Expense Item) 8309.63
- CON-Z3-HRD-LS-420: Expenses: (New Expense Item) 3323.85
- CON-Z3-HRD-LS-430: Expenses: (New Expense Item) 4985.78

| ID | WBS | Activity | Type | Duration | Start | Finish | Predecessors | Total float | Free float | Resources | Cost | RPI_P2 - BOQ ITEMS | RPI_P2 - CONSTRUCTION | RPI_P2 - PHASE | RPI_P2 - ZONES | RPI_P2 - AREAS | RPI_P2 - DISCIPLINE / WORK TYPE | RPI_P2 - BUILDINGS |
| --- | --- | --- | --- | --- | --- | --- | --- | --- | --- | --- | --- | --- | --- | --- | --- | --- | --- | --- |
|  | 3 | **Landscaping (Palm Trees) along New Roads (Road A and Road B) in Zone 3** |  |  | 2017-06-22 | 2017-08-03 |  |  |  |  |  |  |  |  |  |  |  |  |
| CON-Z3-LS-PT-0020 |  | Installation of Palm Trees along Road A |  | 24d | 2017-06-22 | 2017-07-25 | CON-Z3-LS-PT-0010 SS+10d, PR-Z3-LW-LS-93-0080 | 57.2d | 0d | Soft Landscaping Crew [26 h] | 410,044.84 | 1.3.7.30 | CONS | CONS | ZONE-3 | ROAD-A | SOFTSCAPE |  |
| CON-Z3-LS-PT-0030 |  | Installation of Palm Trees along Road B |  | 24d | 2017-07-06 | 2017-08-03 | CON-Z3-LS-PT-0020 SS+8d | 57.2d | 0d | Soft Landscaping Crew [26 h] | 175,733.5 | 1.3.7.30 | CONS | CONS | ZONE-3 | ROAD-B | SOFTSCAPE |  |
|  | 2 | **ANCILLARY BUILDINGS IN PUBLIC REALMS** |  |  | 2017-01-30 | 2017-11-01 |  |  |  |  |  |  |  |  |  |  |  |  |
|  | 1 | **Toilet Facilities (03 No.s Toilets)** |  |  | 2017-05-09 | 2017-11-01 |  |  |  |  |  |  |  |  |  |  |  |  |
|  | 1 | **Toilet Facility # 01** |  |  | 2017-05-09 | 2017-10-25 |  |  |  |  |  |  |  |  |  |  |  |  |
|  | 1 | **Civil Works** |  |  | 2017-05-09 | 2017-05-28 |  |  |  |  |  |  |  |  |  |  |  |  |
| CON-Z3-TL01-CW-0010 |  | Start of Toilet Facility # 1 | milestone | 0d | 2017-05-09 | 2017-05-09 | CON-CON-CON-CON-0010 FS+230d | 0.2d | 0d |  |  | 1.3.8.10 | CONS | CONS | ZONE-3 | REALM |  | Toilet-1 |
| CON-Z3-TL01-CW-0020 |  | Remaining Work for Construction of Slab on Grade |  | 16d | 2017-05-09 | 2017-05-28 | CON-Z3-TL01-CW-0010 | 6.8d | 0d | Steel Fixer [52 h]; Shuttering Carpenter [78 h]; Concrete Mason [78 h]; Common Labor / Helper [78 h] | 25,942.51 | 1.3.8.10 | CONS | CONS | ZONE-3 | REALM |  | Toilet-1 |
|  | 2 | **Architectural Works / Finishes** |  |  | 2017-05-28 | 2017-10-25 |  |  |  |  |  |  |  |  |  |  |  |  |
| CON-Z3-TL01-ARC-0010 |  | Instalaltion of Moisture resistant gypsum board wall on metal stud/ framing system |  | 10d | 2017-05-28 | 2017-06-08 | PR-Z3-GE-GE-232-0080, CON-Z3-TL01-CW-0020 | 6.8d | 0d | Common Labor / Helper [52 h]; Scaffolder [52 h]; Plaster Mason [78 h]; Gypsum Walls & Ceiling Crew [52 h] | 15,133.13 | 1.3.8.10 | CONS | CONS | ZONE-3 | REALM |  | Toilet-1 |
| CON-Z3-TL01-ARC-0020 |  | Instalaltion of Waterproofing Membrane for Wet Area |  | 8d | 2017-06-08 | 2017-06-18 | CON-Z3-TL01-ARC-0010 | 6.8d | 0d | Common Labor / Helper [52 h]; Water Proofing Crew [52 h]; Finishing Work Crew [52 h] | 6,053.25 | 1.3.8.10 | CONS | CONS | ZONE-3 | REALM |  | Toilet-1 |
| CON-Z3-TL01-ARC-0080 |  | Installation of Ceramic Tiles for Floor |  | 25d | 2017-06-12 | 2017-07-16 | CON-Z3-TL01-ARC-0020 SS+3d, PR-Z3-GE-GE-233-0080 | 6.8d | 0d | Common Labor / Helper [104 h]; Block Mason [52 h]; Tiling Crew [52 h] | 30,266.26 | 1.3.8.10 | CONS | CONS | ZONE-3 | REALM |  | Toilet-1 |
| CON-Z3-TL01-ARC-0090 |  | Installation of Ceramic Tiles for Walls |  | 20d | 2017-06-15 | 2017-07-13 | PR-Z3-GE-GE-234-0080, CON-Z3-TL01-ARC-0080 SS+3d | 6.8d | 0d | Common Labor / Helper [104 h]; Block Mason [52 h]; Tiling Crew [52 h] | 30,266.26 | 1.3.8.10 | CONS | CONS | ZONE-3 | REALM |  | Toilet-1 |
| CON-Z3-TL01-ARC-0100 |  | Installation of Ceramic Cover Base |  | 10d | 2017-06-20 | 2017-07-06 | CON-Z3-TL01-ARC-0090 SS+4d | 6.8d | 0d | Block Mason [78 h]; Tiling Crew [52 h] | 9,079.88 | 1.3.8.10 | CONS | CONS | ZONE-3 | REALM |  | Toilet-1 |
| CON-Z3-TL01-ARC-0110 |  | Installation of Moiture resistant gypsum board ceiling |  | 20d | 2017-06-25 | 2017-07-23 | CON-Z3-TL01-ARC-0100 SS+4d | 6.8d | 0d | Common Labor / Helper [52 h]; Scaffolder [52 h]; Plaster Mason [78 h]; Gypsum Walls & Ceiling Crew [52 h] | 30,266.26 | 1.3.8.10 | CONS | CONS | ZONE-3 | REALM |  | Toilet-1 |
| CON-Z3-TL01-ARC-0120 |  | Apply Textured paint finish for ceiling |  | 8d | 2017-07-23 | 2017-08-01 | CON-Z3-TL01-ARC-0110 | 6.8d | 0d | Common Labor / Helper [26 h]; Scaffolder [52 h]; Painter [78 h]; Gypsum Walls & Ceiling Crew [52 h] | 9,079.88 | 1.3.8.10 | CONS | CONS | ZONE-3 | REALM |  | Toilet-1 |
| CON-Z3-TL01-ARC-0160 |  | Installation of Phenolic Toilet Partition |  | 10d | 2017-07-23 | 2017-08-03 | PR-Z3-GE-GE-235-0080, CON-Z3-TL01-ARC-0110 | 37.8d | 0d | Common Labor / Helper [52 h]; Wood Works Crew [52 h] | 15,133.13 | 1.3.8.10 | CONS | CONS | ZONE-3 | REALM |  | Toilet-1 |
| CON-Z3-TL01-ARC-0130 |  | Installation of Roof Waterproofing System |  | 8d | 2017-08-01 | 2017-08-10 | CON-Z3-TL01-ARC-0120 | 6.8d | 0d | Common Labor / Helper [52 h]; Water Proofing Crew [52 h]; Finishing Work Crew [52 h] | 15,133.13 | 1.3.8.10 | CONS | CONS | ZONE-3 | REALM |  | Toilet-1 |
| CON-Z3-TL01-ARC-0140 |  | Internal Palstering and Painting |  | 20d | 2017-08-10 | 2017-09-07 | CON-Z3-TL01-ARC-0130, CON-Z3-TL01-ARC-0020 | 6.8d | 0d | Common Labor / Helper [26 h]; Scaffolder [52 h]; Painter [78 h] | 30,266.26 | 1.3.8.10 | CONS | CONS | ZONE-3 | REALM |  | Toilet-1 |
| CON-Z3-TL01-ARC-0150 |  | External Painting |  | 5d | 2017-09-07 | 2017-09-13 | CON-Z3-TL01-ARC-0140 | 6.8d | 0d | Common Labor / Helper [390 h]; Scaffolder [195 h]; Painter [260 h] | 6,053.25 | 1.3.8.10 | CONS | CONS | ZONE-3 | REALM |  | Toilet-1 |
| CON-Z3-TL01-ARC-0170 |  | Installation of Doors and Windows |  | 16d | 2017-09-13 | 2017-10-03 | CON-Z3-TL01-ARC-0150, CON-Z3-TL01-ARC-0160 | 6.8d | 0d | Shuttering Carpenter [624 h]; Common Labor / Helper [1248 h] | 30,266.26 | 1.3.8.10 | CONS | CONS | ZONE-3 | REALM |  | Toilet-1 |
| CON-Z3-TL01-ARC-0180 |  | Instalaltion of Cabinet and Counter Top and Glass blocks |  | 5d | 2017-10-03 | 2017-10-09 | PR-Z3-GE-GE-231-0080, CON-Z3-TL01-ARC-0170, PR-Z3-GE-GE-236-0080 | 6.8d | 0d | Concrete Mason [100 h]; Common Labor / Helper [750 h] | 15,133.13 | 1.3.8.10 | CONS | CONS | ZONE-3 | REALM |  | Toilet-1 |
| CON-Z3-TL01-ARC-0190 |  | Instalaltion of Toilet Fixures and Accessories |  | 19d | 2017-10-03 | 2017-10-25 | CON-Z3-TL01-ARC-0180 SS, PR-Z3-GE-GE-228-0080, PR-Z3-CW-MS-34-0080, PR-Z3-CW-MS-35-0080 | 6.8d | 0d | Common Labor / Helper [3800 h] | 60,532.51 | 1.3.8.10 | CONS | CONS | ZONE-3 | REALM |  | Toilet-1 |

Notes:
- CON-Z3-LS-PT-0020: Expenses: (New Expense Item) 410045
- CON-Z3-LS-PT-0030: Expenses: (New Expense Item) 175734
- CON-Z3-TL01-CW-0020: Expenses: (New Expense Item) 25942.5
- CON-Z3-TL01-ARC-0010: Expenses: (New Expense Item) 15133.1
- CON-Z3-TL01-ARC-0020: Expenses: (New Expense Item) 6053.25
- CON-Z3-TL01-ARC-0080: Expenses: (New Expense Item) 30266.3
- CON-Z3-TL01-ARC-0090: Expenses: (New Expense Item) 30266.3
- CON-Z3-TL01-ARC-0100: Expenses: (New Expense Item) 9079.88
- CON-Z3-TL01-ARC-0110: Expenses: (New Expense Item) 30266.3
- CON-Z3-TL01-ARC-0120: Expenses: (New Expense Item) 9079.88
- CON-Z3-TL01-ARC-0160: Expenses: (New Expense Item) 15133.1
- CON-Z3-TL01-ARC-0130: Expenses: (New Expense Item) 15133.1
- CON-Z3-TL01-ARC-0140: Expenses: (New Expense Item) 30266.3
- CON-Z3-TL01-ARC-0150: Expenses: (New Expense Item) 6053.25
- CON-Z3-TL01-ARC-0170: Expenses: (New Expense Item) 30266.3
- CON-Z3-TL01-ARC-0180: Expenses: (New Expense Item) 15133.1
- CON-Z3-TL01-ARC-0190: Expenses: (New Expense Item) 60532.5

| ID | WBS | Activity | Type | Duration | Start | Finish | Predecessors | Total float | Free float | Resources | Cost | RPI_P2 - BOQ ITEMS | RPI_P2 - CONSTRUCTION | RPI_P2 - PHASE | RPI_P2 - ZONES | RPI_P2 - AREAS | RPI_P2 - BUILDINGS | Activity Wt% | Weight % | Cost Wt | RPI - PHASE | RPI - CONSTRUCTION | RPI - ZONES | RPI - BUILDINGS | RPI - TYPE OF WORK |
| --- | --- | --- | --- | --- | --- | --- | --- | --- | --- | --- | --- | --- | --- | --- | --- | --- | --- | --- | --- | --- | --- | --- | --- | --- | --- |
|  | 3 | **Electrical Works** |  |  | 2017-07-23 | 2017-08-22 |  |  |  |  |  |  |  |  |  |  |  |  |  |  |  |  |  |  |  |
| CON-Z3-TL01-ELE-0010 |  | Instalaltion of Eelectric Wiring Devices,Cables ,Disconnect Switches,Power Outlets,Junction Boxes and Accessories |  | 25d | 2017-07-23 | 2017-08-21 | CON-Z3-TL01-ARC-0160 SS | 43.4d | 0d | Electrician [52 h]; LC Crew [52 h] | 77,827.52 | 1.3.8.10 | CONS | CONS | ZONE-3 | REALM | Toilet-1 |  |  |  |  |  |  |  |  |
| CON-Z3-TL01-ELE-0020 |  | Installation of Internal and External Lighting Fixures and Accessories |  | 20d | 2017-07-29 | 2017-08-21 | CON-Z3-TL01-ELE-0010 SS+5d, PR-Z3-EW-ME-65-0080 | 45d | 1.6d | Electrician [52 h]; LC Crew [52 h] | 38,913.76 | 1.3.8.10 | CONS | CONS | ZONE-3 | REALM | Toilet-1 |  |  |  |  |  |  |  |  |
| CON-Z3-TL01-ELE-0030 |  | Instalaltion of Water Heator |  | 1.6d | 2017-08-21 | 2017-08-22 | CON-Z3-TL01-ELE-0010 | 43.4d | 0d | Electrician [52 h]; LC Crew [52 h] | 12,971.25 | 1.3.8.10 | CONS | CONS | ZONE-3 | REALM | Toilet-1 |  |  |  |  |  |  |  |  |
|  | 4 | **Mechanical Works** |  |  | 2017-05-09 | 2017-08-05 |  |  |  |  |  |  |  |  |  |  |  |  |  |  |  |  |  |  |  |
| CON-Z3-TL01-ME-0010 |  | Instalation of Potable Water Supply Lines |  | 15d | 2017-05-09 | 2017-05-27 | CON-Z3-TL01-CW-0010 | 60.6d | 0d | Plumber [78 h]; Common Labor / Helper [78 h] | 43,237.51 | 1.3.8.10 | CONS | CONS | ZONE-3 | REALM | Toilet-1 |  |  |  |  |  |  |  |  |
| CON-Z3-TL01-ME-0030 |  | Installation of Hot Water Lines and Accessories |  | 15d | 2017-05-09 | 2017-05-27 | CON-Z3-TL01-ME-0010 SS | 118.2d | 10d | Plumber [78 h]; Common Labor / Helper [52 h] | 21,618.76 | 1.3.8.10 | CONS | CONS | ZONE-3 | REALM | Toilet-1 |  |  |  |  |  |  |  |  |
| CON-Z3-TL01-ME-0020 |  | Installation of Valves and Fittings for Potable Water Supply Ssytem |  | 10d | 2017-05-27 | 2017-06-07 | CON-Z3-TL01-ME-0010 | 108.2d | 0d | Common Labor / Helper [26 h]; RTR Pipe Crew [26 h] | 21,618.76 | 1.3.8.10 | CONS | CONS | ZONE-3 | REALM | Toilet-1 |  |  |  |  |  |  |  |  |
| CON-Z3-TL01-ME-0040 |  | Instalaltion of Sanitary Sewer Lines and Accessories |  | 20d | 2017-05-27 | 2017-06-19 | CON-Z3-TL01-ME-0010 | 60.6d | 0d | Plumber [78 h]; Common Labor / Helper [52 h] | 43,237.51 | 1.3.8.10 | CONS | CONS | ZONE-3 | REALM | Toilet-1 |  |  |  |  |  |  |  |  |
| CON-Z3-TL01-ME-0050 |  | Instalaltion of floor drains and clean out |  | 4d | 2017-06-19 | 2017-06-24 | CON-Z3-TL01-ME-0040 | 60.6d | 0d | Plumber [52 h]; Common Labor / Helper [52 h] | 10,809.38 | 1.3.8.10 | CONS | CONS | ZONE-3 | REALM | Toilet-1 |  |  |  |  |  |  |  |  |
| CON-Z3-TL01-ME-0060 |  | Installation of Gulvanized Steel duct |  | 12d | 2017-06-24 | 2017-07-12 | PR-Z3-GE-GE-238-0080, CON-Z3-TL01-ME-0050 | 60.6d | 0d | HVAC Crew [26 h] | 21,618.76 | 1.3.8.10 | CONS | CONS | ZONE-3 | REALM | Toilet-1 |  |  |  |  |  |  |  |  |
| CON-Z3-TL01-ME-0070 |  | Instalaltion of Exhaust Ceiling Diffuser |  | 8d | 2017-07-12 | 2017-07-22 | CON-Z3-TL01-ME-0060 | 60.6d | 0d | Mechanical Technician [26 h]; Common Labor / Helper [26 h] | 10,809.38 | 1.3.8.10 | CONS | CONS | ZONE-3 | REALM | Toilet-1 |  |  |  |  |  |  |  |  |
| CON-Z3-TL01-ME-0080 |  | Installation of Exhaust Fans (EF-1,EF-2,EF-3,EF-4) |  | 4d | 2017-07-22 | 2017-07-26 | CON-Z3-TL01-ME-0070 | 60.6d | 0d | Mechanical Technician [26 h]; Common Labor / Helper [52 h] | 21,618.76 | 1.3.8.10 | CONS | CONS | ZONE-3 | REALM | Toilet-1 |  |  |  |  |  |  |  |  |
| CON-Z3-TL01-ME-0090 |  | Installation of Volume Control Dampers |  | 4d | 2017-07-26 | 2017-07-31 | CON-Z3-TL01-ME-0080 | 60.6d | 0d | Electrician [26 h]; Common Labor / Helper [52 h] | 10,809.38 | 1.3.8.10 | CONS | CONS | ZONE-3 | REALM | Toilet-1 |  |  |  |  |  |  |  |  |
| CON-Z3-TL01-ME-0100 |  | Instalaltion of Fire Extinguisher |  | 4d | 2017-07-31 | 2017-08-05 | CON-Z3-TL01-ME-0090, CON-Z3-TL01-ME-0080, PR-Z3-GE-GE-241-0080 | 60.6d | 0d | Mechanical Technician [26 h]; Common Labor / Helper [52 h] | 10,809.38 | 1.3.8.10 | CONS | CONS | ZONE-3 | REALM | Toilet-1 |  |  |  |  |  |  |  |  |
|  | 5 | **External Works** |  |  | 2017-09-13 | 2017-10-11 |  |  |  |  |  |  |  |  |  |  |  |  |  |  |  |  |  |  |  |
| CON-Z3-TL01-EW-0010 |  | General Backfilling for External Works |  | 6.4d | 2017-09-13 | 2017-09-20 | CON-Z3-TL01-ARC-0150 | 18.4d | 0d | Common Labor / Helper [499.2 h]; Operator - Loader [26 h]; Driver - Dump Truck [26 h]; Operator - Bobcat [26 h]; Operator - Roller-Compactor (2~10 Ton) [26 h]; Operator - Roller (25 Ton) [26 h]; Driver - Water Tanker [26 h]; Loader [28 h]; Dump Truck [28 h]; Bobcat [28 h]; Roller-Compactor (2~10 Ton) [28 h]; Roller-Compactor (25 Ton) [28 h]; Water Tanker [28 h] | 12,106.5 | 1.3.8.10 | CONS | CONS | ZONE-3 | REALM | Toilet-1 |  |  |  |  |  |  |  |  |
| CON-Z3-TL01-EW-0020 |  | Installation of Side workway (Apron around the building) |  | 12d | 2017-09-20 | 2017-10-05 | CON-Z3-TL01-EW-0010 | 18.4d | 0d | Steel Fixer [468 h]; Shuttering Carpenter [624 h]; Concrete Mason [624 h]; Common Labor / Helper [936 h] | 36,319.51 | 1.3.8.10 | CONS | CONS | ZONE-3 | REALM | Toilet-1 |  |  |  |  |  |  |  |  |
| CON-Z3-TL01-EW-0030 |  | Instalaltion of Sign Boards |  | 5d | 2017-10-05 | 2017-10-11 | CON-Z3-TL01-EW-0020, PR-Z3-CW-MS-28-0080 | 18.4d | 11.6d | Shuttering Carpenter [250 h]; Common Labor / Helper [500 h] | 12,106.5 | 1.3.8.10 | CONS | CONS | ZONE-3 | REALM | Toilet-1 |  |  |  |  |  |  |  |  |
|  | 6 | **Testing & Pre-Commissioning** |  |  | 2017-06-07 | 2017-10-25 |  |  |  |  |  |  |  |  |  |  |  |  |  |  |  |  |  |  |  |
| CON-Z3-Tl01-TC-0010 |  | Hydro Testing - Plumbing Works |  | 9.6d | 2017-06-07 | 2017-06-18 | CON-Z3-TL01-ME-0020, CON-Z3-TL01-ME-0010, CON-Z3-TL01-ME-0030 | 108.2d | 101.4d | Plumber [26 h]; Common Labor / Helper [52 h]; Driver - Water Tanker [26 h] | 51,885.01 | 1.3.8.10 | CONS | CONS | ZONE-3 | REALM | Toilet-1 | 0 | 0 | 0.0085280982 | 6 | RPI - CONS | Z2 | LS12 | MECH |
| CON-Z3-Tl01-TC-0020 |  | Testing & Balancing of HVAC System |  | 11.2d | 2017-07-22 | 2017-08-03 | CON-Z3-TL01-ME-0070, CON-Z3-TL01-ME-0060 | 72.6d | 12d | Mechanical Technician [26 h]; HVAC Crew [26 h] | 19,456.88 | 1.3.8.10 | CONS | CONS | ZONE-3 | REALM | Toilet-1 | 0 | 0 | 0.0255842733 | 6 | RPI - CONS | Z2 | LS12 | MECH |
| CON-Z3-Tl01-TC-0030 |  | Testing & Pre-commissioning of Mechanical Works |  | 11.2d | 2017-08-05 | 2017-08-17 | CON-Z3-TL01-ME-0080, CON-Z3-TL01-ME-0100, CON-Z3-Tl01-TC-0020 SS | 60.6d | 53.8d | Mechanical Technician [52 h]; Specialist Works Crew [26 h] | 19,456.88 | 1.3.8.10 | CONS | CONS | ZONE-3 | REALM | Toilet-1 | 0 | 0 | 0.0511685254 | 6 | RPI - CONS | Z2 | LS12 | MECH |
| CON-Z3-Tl01-TC-0040 |  | Testing & Pre-commissioning of Electrical Works |  | 12.8d | 2017-08-22 | 2017-09-11 | CON-Z3-TL01-ELE-0030, CON-Z3-TL01-ELE-0020, CON-Z3-TL01-ELE-0010 | 43.4d | 36.6d | Electrician [78 h]; LC Crew [52 h] | 38,913.76 | 1.3.8.10 | CONS | CONS | ZONE-3 | REALM | Toilet-1 | 0 | 0 | 0.0248538226 | 6 | RPI - CONS | Z2 | LS12 | ELEC |
| CON-Z3-Tl01-TC-0050 |  | Completion of Toilet # 1 | milestone | 0d | 2017-10-25 | 2017-10-25 | CON-Z3-Tl01-TC-0020 FF, CON-Z3-Tl01-TC-0030, CON-Z3-Tl01-TC-0010, CON-Z3-Tl01-TC-0040, CON-Z3-TL01-ARC-0190, CON-Z3-Tl01-TC-0020, CON-Z3-TL01-EW-0030 | 6.8d | 6.6d |  |  | 1.3.8.10 | CONS | CONS | ZONE-3 | REALM | Toilet-1 | 0 | 0 | 0 | 6 | RPI - CONS | Z2 | LS12 | CIVIL |

Notes:
- CON-Z3-TL01-ELE-0010: Expenses: (New Expense Item) 77827.5
- CON-Z3-TL01-ELE-0020: Expenses: (New Expense Item) 38913.8
- CON-Z3-TL01-ELE-0030: Expenses: (New Expense Item) 12971.2
- CON-Z3-TL01-ME-0010: Expenses: (New Expense Item) 43237.5
- CON-Z3-TL01-ME-0030: Expenses: (New Expense Item) 21618.8
- CON-Z3-TL01-ME-0020: Expenses: (New Expense Item) 21618.8
- CON-Z3-TL01-ME-0040: Expenses: (New Expense Item) 43237.5
- CON-Z3-TL01-ME-0050: Expenses: (New Expense Item) 10809.4
- CON-Z3-TL01-ME-0060: Expenses: (New Expense Item) 21618.8
- CON-Z3-TL01-ME-0070: Expenses: (New Expense Item) 10809.4
- CON-Z3-TL01-ME-0080: Expenses: (New Expense Item) 21618.8
- CON-Z3-TL01-ME-0090: Expenses: (New Expense Item) 10809.4
- CON-Z3-TL01-ME-0100: Expenses: (New Expense Item) 10809.4
- CON-Z3-TL01-EW-0010: Expenses: (New Expense Item) 12106.5
- CON-Z3-TL01-EW-0020: Expenses: (New Expense Item) 36319.5
- CON-Z3-TL01-EW-0030: Expenses: (New Expense Item) 12106.5
- CON-Z3-Tl01-TC-0010: Expenses: (New Expense Item) 51885
- CON-Z3-Tl01-TC-0020: Expenses: (New Expense Item) 19456.9
- CON-Z3-Tl01-TC-0030: Expenses: (New Expense Item) 19456.9
- CON-Z3-Tl01-TC-0040: Expenses: (New Expense Item) 38913.8

| ID | WBS | Activity | Type | Duration | Start | Finish | Predecessors | Total float | Free float | Resources | Cost | RPI_P2 - BOQ ITEMS | RPI_P2 - CONSTRUCTION | RPI_P2 - PHASE | RPI_P2 - ZONES | RPI_P2 - AREAS | RPI_P2 - BUILDINGS |
| --- | --- | --- | --- | --- | --- | --- | --- | --- | --- | --- | --- | --- | --- | --- | --- | --- | --- |
|  | 7 | **Toilet Facility # 02** |  |  | 2017-05-27 | 2017-10-29 |  |  |  |  |  |  |  |  |  |  |  |
|  | 1 | **Civil Works** |  |  | 2017-05-27 | 2017-06-14 |  |  |  |  |  |  |  |  |  |  |  |
| CON-Z3-TL01-CW-20 |  | Start of Toilet Facility # 2 | milestone | 0d | 2017-05-27 | 2017-05-27 | CON-Z3-TL01-CW-0010 FS+15d | 0.2d | 0d |  |  | 1.3.8.10 | CONS | CONS | ZONE-3 | REALM | Toilet-2 |
| CON-Z3-TL01-CW-30 |  | Remaining Work for Construction of Slab on Grade |  | 16d | 2017-05-27 | 2017-06-14 | CON-Z3-TL01-CW-20 | 3d | 0d | Steel Fixer [52 h]; Shuttering Carpenter [78 h]; Concrete Mason [78 h]; Common Labor / Helper [78 h] | 25,942.51 | 1.3.8.10 | CONS | CONS | ZONE-3 | REALM | Toilet-2 |
|  | 2 | **Architectural Works / Finishes** |  |  | 2017-06-14 | 2017-10-12 |  |  |  |  |  |  |  |  |  |  |  |
| CON-Z3-TL01-ARC-190 |  | Instalaltion of Moisture resistant gypsum board wall on metal stud/ framing system |  | 10d | 2017-06-14 | 2017-07-01 | CON-Z3-TL01-CW-30 | 3d | 0d | Common Labor / Helper [52 h]; Scaffolder [52 h]; Plaster Mason [78 h]; Gypsum Walls & Ceiling Crew [52 h] | 15,133.13 | 1.3.8.10 | CONS | CONS | ZONE-3 | REALM | Toilet-2 |
| CON-Z3-TL01-ARC-200 |  | Instalaltion of Waterproofing Membrane for Wet Area |  | 8d | 2017-07-01 | 2017-07-10 | CON-Z3-TL01-ARC-190 | 3d | 0d | Common Labor / Helper [52 h]; Water Proofing Crew [52 h]; Finishing Work Crew [52 h] | 6,053.25 | 1.3.8.10 | CONS | CONS | ZONE-3 | REALM | Toilet-2 |
| CON-Z3-TL01-ARC-210 |  | Installation of Ceramic Tiles for Floor |  | 25d | 2017-07-05 | 2017-08-03 | CON-Z3-TL01-ARC-200 SS+4d | 3d | 0d | Common Labor / Helper [104 h]; Block Mason [52 h]; Tiling Crew [52 h] | 30,266.26 | 1.3.8.10 | CONS | CONS | ZONE-3 | REALM | Toilet-2 |
| CON-Z3-TL01-ARC-220 |  | Installation of Ceramic Tiles for Walls |  | 20d | 2017-07-10 | 2017-08-02 | CON-Z3-TL01-ARC-210 SS+4d | 3d | 0d | Common Labor / Helper [104 h]; Block Mason [52 h]; Tiling Crew [52 h] | 30,266.26 | 1.3.8.10 | CONS | CONS | ZONE-3 | REALM | Toilet-2 |
| CON-Z3-TL01-ARC-230 |  | Installation of Ceramic Cover Base |  | 10d | 2017-07-15 | 2017-07-26 | CON-Z3-TL01-ARC-220 SS+4d | 3d | 0d | Block Mason [78 h]; Tiling Crew [52 h] | 9,079.88 | 1.3.8.10 | CONS | CONS | ZONE-3 | REALM | Toilet-2 |
| CON-Z3-TL01-ARC-240 |  | Installation of Moiture resistant gypsum board ceiling |  | 20d | 2017-07-19 | 2017-08-12 | CON-Z3-TL01-ARC-230 SS+4d | 3d | 0d | Common Labor / Helper [52 h]; Scaffolder [52 h]; Plaster Mason [78 h]; Gypsum Walls & Ceiling Crew [52 h] | 30,266.26 | 1.3.8.10 | CONS | CONS | ZONE-3 | REALM | Toilet-2 |
| CON-Z3-TL01-ARC-290 |  | Installation of Phenolic Toilet Partition |  | 10d | 2017-07-19 | 2017-07-31 | CON-Z3-TL01-ARC-240 SS | 41d | 38d | Common Labor / Helper [52 h]; Wood Works Crew [52 h] | 15,133.13 | 1.3.8.10 | CONS | CONS | ZONE-3 | REALM | Toilet-2 |
| CON-Z3-TL01-ARC-250 |  | Apply Textured paint finish for ceiling |  | 8d | 2017-08-12 | 2017-08-21 | CON-Z3-TL01-ARC-240 | 3d | 0d | Common Labor / Helper [26 h]; Scaffolder [52 h]; Painter [78 h]; Gypsum Walls & Ceiling Crew [52 h] | 9,079.88 | 1.3.8.10 | CONS | CONS | ZONE-3 | REALM | Toilet-2 |
| CON-Z3-TL01-ARC-260 |  | Installation of Roof Waterproofing System |  | 8d | 2017-08-21 | 2017-08-30 | CON-Z3-TL01-ARC-250 | 3d | 0d | Common Labor / Helper [52 h]; Water Proofing Crew [52 h]; Finishing Work Crew [52 h] | 15,133.13 | 1.3.8.10 | CONS | CONS | ZONE-3 | REALM | Toilet-2 |
| CON-Z3-TL01-ARC-270 |  | Internal Palstering and Painting |  | 20d | 2017-08-21 | 2017-09-18 | CON-Z3-TL01-ARC-200, CON-Z3-TL01-ARC-260 SS | 3d | 0d | Common Labor / Helper [26 h]; Scaffolder [52 h]; Painter [78 h] | 30,266.26 | 1.3.8.10 | CONS | CONS | ZONE-3 | REALM | Toilet-2 |
| CON-Z3-TL01-ARC-280 |  | External Painting |  | 5d | 2017-09-18 | 2017-09-25 | CON-Z3-TL01-ARC-270 | 3d | 0d | Common Labor / Helper [260 h]; Scaffolder [195 h]; Painter [325 h] | 6,053.25 | 1.3.8.10 | CONS | CONS | ZONE-3 | REALM | Toilet-2 |
| CON-Z3-TL01-ARC-300 |  | Installation of Doors and Windows |  | 16d | 2017-09-18 | 2017-10-08 | CON-Z3-TL01-ARC-280 SS, CON-Z3-TL01-ARC-290 | 3d | 0d | Shuttering Carpenter [624 h]; Common Labor / Helper [832 h] | 30,266.26 | 1.3.8.10 | CONS | CONS | ZONE-3 | REALM | Toilet-2 |
| CON-Z3-TL01-ARC-310 |  | Instalaltion of Cabinet and Counter Top and Glass blocks |  | 5d | 2017-09-18 | 2017-09-25 | CON-Z3-TL01-ARC-300 SS | 3d | 0d | Concrete Mason [260 h]; Common Labor / Helper [390 h] | 15,133.13 | 1.3.8.10 | CONS | CONS | ZONE-3 | REALM | Toilet-2 |
| CON-Z3-TL01-ARC-320 |  | Instalaltion of Toilet Fixures and Accessories |  | 20d | 2017-09-18 | 2017-10-12 | CON-Z3-TL01-ARC-310 SS | 3d | 0d | Common Labor / Helper [1300 h] | 60,532.51 | 1.3.8.10 | CONS | CONS | ZONE-3 | REALM | Toilet-2 |
|  | 3 | **Electrical Works** |  |  | 2017-09-20 | 2017-10-15 |  |  |  |  |  |  |  |  |  |  |  |
| CON-Z3-TL01-ELE-30 |  | Instalaltion of Eelectric Wiring Devices,Cables ,Disconnect Switches,Power Outlets,Junction Boxes and Accessories |  | 20d | 2017-09-20 | 2017-10-15 | CON-Z3-TL01-ARC-320 SS+2d | 3d | 0d | Electrician [1040 h]; LC Crew [520 h] | 77,827.52 | 1.3.8.10 | CONS | CONS | ZONE-3 | REALM | Toilet-2 |
| CON-Z3-TL01-ELE-50 |  | Instalaltion of Water Heator |  | 1.6d | 2017-09-20 | 2017-09-21 | CON-Z3-TL01-ELE-30 SS | 34.2d | 31.2d | Electrician [52 h]; LC Crew [52 h] | 12,971.25 | 1.3.8.10 | CONS | CONS | ZONE-3 | REALM | Toilet-2 |
| CON-Z3-TL01-ELE-40 |  | Installation of Internal and External Lighting Fixures and Accessories |  | 15d | 2017-09-27 | 2017-10-15 | PR-Z3-EW-ME-65-0080, CON-Z3-TL01-ELE-30 SS+5d | 3d | 0d | Electrician [780 h]; LC Crew [390 h] | 38,913.76 | 1.3.8.10 | CONS | CONS | ZONE-3 | REALM | Toilet-2 |
|  | 4 | **Mechanical Works** |  |  | 2017-05-27 | 2017-08-22 |  |  |  |  |  |  |  |  |  |  |  |
| CON-Z3-TL01-ME-140 |  | Instalation of Potable Water Supply Lines |  | 15d | 2017-05-27 | 2017-06-13 | CON-Z3-TL01-CW-20 | 45.6d | 0d | Plumber [78 h]; Common Labor / Helper [78 h] | 10,809.38 | 1.3.8.10 | CONS | CONS | ZONE-3 | REALM | Toilet-2 |
| CON-Z3-TL01-ME-160 |  | Installation of Hot Water Lines and Accessories |  | 15d | 2017-05-27 | 2017-06-13 | CON-Z3-TL01-ME-140 SS | 103.2d | 0.4d | Plumber [78 h]; Common Labor / Helper [52 h] | 10,809.38 | 1.3.8.10 | CONS | CONS | ZONE-3 | REALM | Toilet-2 |
| CON-Z3-TL01-ME-150 |  | Installation of Valves and Fittings for Potable Water Supply Ssytem |  | 10d | 2017-06-13 | 2017-06-25 | CON-Z3-TL01-ME-140 | 102.8d | 0d | Common Labor / Helper [26 h]; RTR Pipe Crew [26 h] | 21,618.76 | 1.3.8.10 | CONS | CONS | ZONE-3 | REALM | Toilet-2 |
| CON-Z3-TL01-ME-170 |  | Instalaltion of Sanitary Sewer Lines and Accessories |  | 20d | 2017-06-13 | 2017-07-11 | CON-Z3-TL01-ME-140 | 45.6d | 0d | Plumber [78 h]; Common Labor / Helper [52 h] | 21,618.76 | 1.3.8.10 | CONS | CONS | ZONE-3 | REALM | Toilet-2 |
| CON-Z3-TL01-ME-180 |  | Instalaltion of floor drains and clean out |  | 4d | 2017-07-11 | 2017-07-16 | CON-Z3-TL01-ME-170 | 45.6d | 0d | Plumber [52 h]; Common Labor / Helper [52 h] | 10,809.38 | 1.3.8.10 | CONS | CONS | ZONE-3 | REALM | Toilet-2 |
| CON-Z3-TL01-ME-100 |  | Installation of Gulvanized Steel duct |  | 12d | 2017-07-16 | 2017-07-30 | CON-Z3-TL01-ME-180, PR-Z3-GE-GE-238-0080 | 45.6d | 0d | HVAC Crew [26 h] | 43,237.51 | 1.3.8.10 | CONS | CONS | ZONE-3 | REALM | Toilet-2 |
| CON-Z3-TL01-ME-110 |  | Instalaltion of Exhaust Ceiling Diffuser |  | 8d | 2017-07-30 | 2017-08-08 | CON-Z3-TL01-ME-100 | 45.6d | 0d | Mechanical Technician [26 h]; Common Labor / Helper [26 h] | 21,618.76 | 1.3.8.10 | CONS | CONS | ZONE-3 | REALM | Toilet-2 |
| CON-Z3-TL01-ME-120 |  | Installation of Exhaust Fans (EF-1,EF-2,EF-3,EF-4) |  | 4d | 2017-08-08 | 2017-08-13 | PR-Z3-EW-ME-63-0080, CON-Z3-TL01-ME-110 | 45.6d | 0d | Mechanical Technician [26 h]; Common Labor / Helper [52 h] | 21,618.76 | 1.3.8.10 | CONS | CONS | ZONE-3 | REALM | Toilet-2 |
| CON-Z3-TL01-ME-130 |  | Installation of Volume Control Dampers |  | 4d | 2017-08-13 | 2017-08-17 | CON-Z3-TL01-ME-120 | 45.6d | 0d | Electrician [26 h]; Common Labor / Helper [52 h] | 43,237.51 | 1.3.8.10 | CONS | CONS | ZONE-3 | REALM | Toilet-2 |
| CON-Z3-TL01-ME-190 |  | Instalaltion of Fire Extinguisher |  | 4d | 2017-08-17 | 2017-08-22 | PR-Z3-GE-GE-241-0080, CON-Z3-TL01-ME-130, CON-Z3-TL01-ME-120 | 45.6d | 0d | Mechanical Technician [26 h]; Common Labor / Helper [52 h] | 10,809.38 | 1.3.8.10 | CONS | CONS | ZONE-3 | REALM | Toilet-2 |

Notes:
- CON-Z3-TL01-CW-30: Expenses: (New Expense Item) 25942.5
- CON-Z3-TL01-ARC-190: Expenses: (New Expense Item) 15133.1
- CON-Z3-TL01-ARC-200: Expenses: (New Expense Item) 6053.25
- CON-Z3-TL01-ARC-210: Expenses: (New Expense Item) 30266.3
- CON-Z3-TL01-ARC-220: Expenses: (New Expense Item) 30266.3
- CON-Z3-TL01-ARC-230: Expenses: (New Expense Item) 9079.88
- CON-Z3-TL01-ARC-240: Expenses: (New Expense Item) 30266.3
- CON-Z3-TL01-ARC-290: Expenses: (New Expense Item) 15133.1
- CON-Z3-TL01-ARC-250: Expenses: (New Expense Item) 9079.88
- CON-Z3-TL01-ARC-260: Expenses: (New Expense Item) 15133.1
- CON-Z3-TL01-ARC-270: Expenses: (New Expense Item) 30266.3
- CON-Z3-TL01-ARC-280: Expenses: (New Expense Item) 6053.25
- CON-Z3-TL01-ARC-300: Expenses: (New Expense Item) 30266.3
- CON-Z3-TL01-ARC-310: Expenses: (New Expense Item) 15133.1
- CON-Z3-TL01-ARC-320: Expenses: (New Expense Item) 60532.5
- CON-Z3-TL01-ELE-30: Expenses: (New Expense Item) 77827.5
- CON-Z3-TL01-ELE-50: Expenses: (New Expense Item) 12971.2
- CON-Z3-TL01-ELE-40: Expenses: (New Expense Item) 38913.8
- CON-Z3-TL01-ME-140: Expenses: (New Expense Item) 10809.4
- CON-Z3-TL01-ME-160: Expenses: (New Expense Item) 10809.4
- CON-Z3-TL01-ME-150: Expenses: (New Expense Item) 21618.8
- CON-Z3-TL01-ME-170: Expenses: (New Expense Item) 21618.8
- CON-Z3-TL01-ME-180: Expenses: (New Expense Item) 10809.4
- CON-Z3-TL01-ME-100: Expenses: (New Expense Item) 43237.5
- CON-Z3-TL01-ME-110: Expenses: (New Expense Item) 21618.8
- CON-Z3-TL01-ME-120: Expenses: (New Expense Item) 21618.8
- CON-Z3-TL01-ME-130: Expenses: (New Expense Item) 43237.5
- CON-Z3-TL01-ME-190: Expenses: (New Expense Item) 10809.4

| ID | WBS | Activity | Type | Duration | Start | Finish | Predecessors | Total float | Free float | Resources | Cost | RPI_P2 - BOQ ITEMS | RPI_P2 - CONSTRUCTION | RPI_P2 - PHASE | RPI_P2 - ZONES | RPI_P2 - AREAS | RPI_P2 - BUILDINGS | Activity Wt% | Weight % | Cost Wt | RPI - PHASE | RPI - CONSTRUCTION | RPI - ZONES | RPI - BUILDINGS | RPI - TYPE OF WORK |
| --- | --- | --- | --- | --- | --- | --- | --- | --- | --- | --- | --- | --- | --- | --- | --- | --- | --- | --- | --- | --- | --- | --- | --- | --- | --- |
|  | 5 | **External Works** |  |  | 2017-09-25 | 2017-10-22 |  |  |  |  |  |  |  |  |  |  |  |  |  |  |  |  |  |  |  |
| CON-Z3-TL01-EW-30 |  | General Backfilling for External Works |  | 6.4d | 2017-09-25 | 2017-10-02 | CON-Z3-TL01-ARC-280 | 9.4d | 0d | Operator - Roller (25 Ton) [26 h]; Driver - Water Tanker [26 h]; Loader [28 h]; Dump Truck [28 h]; Bobcat [28 h]; Roller-Compactor (2~10 Ton) [28 h]; Roller-Compactor (25 Ton) [28 h]; Water Tanker [28 h]; Common Labor / Helper [41.6 h]; Operator - Loader [26 h]; Driver - Dump Truck [26 h]; Operator - Bobcat [26 h]; Operator - Roller-Compactor (2~10 Ton) [26 h] | 12,106.5 | 1.3.8.10 | CONS | CONS | ZONE-3 | REALM | Toilet-2 |  |  |  |  |  |  |  |  |
| CON-Z3-TL01-EW-40 |  | Installation of Side workway (Apron around the building) |  | 12d | 2017-10-02 | 2017-10-16 | CON-Z3-TL01-EW-30 | 9.4d | 0d | Steel Fixer [600 h]; Shuttering Carpenter [600 h]; Concrete Mason [600 h]; Common Labor / Helper [1800 h] | 36,319.51 | 1.3.8.10 | CONS | CONS | ZONE-3 | REALM | Toilet-2 |  |  |  |  |  |  |  |  |
| CON-Z3-TL01-EW-50 |  | Instalaltion of Sign Boards |  | 5d | 2017-10-16 | 2017-10-22 | PR-Z3-GE-GE-216-0080, CON-Z3-TL01-EW-40, PR-Z3-GE-GE-217-0080 | 9.4d | 6.4d | Shuttering Carpenter [500 h]; Common Labor / Helper [750 h] | 12,106.5 | 1.3.8.10 | CONS | CONS | ZONE-3 | REALM | Toilet-2 |  |  |  |  |  |  |  |  |
|  | 6 | **Testing & Pre-Commissioning** |  |  | 2017-06-13 | 2017-10-29 |  |  |  |  |  |  |  |  |  |  |  |  |  |  |  |  |  |  |  |
| CON-Z3-Tl01-TC-50 |  | Hydro Testing - Plumbing Works |  | 9.6d | 2017-06-13 | 2017-06-25 | CON-Z3-TL01-ME-160, CON-Z3-TL01-ME-140, CON-Z3-TL01-ME-150 FF | 102.8d | 99.8d | Plumber [26 h]; Common Labor / Helper [52 h]; Driver - Water Tanker [26 h] | 51,885.01 | 1.3.8.10 | CONS | CONS | ZONE-3 | REALM | Toilet-2 | 0 | 0 | 0.0085280982 | 6 | RPI - CONS | Z2 | LS12 | MECH |
| CON-Z3-Tl01-TC-60 |  | Testing & Balancing of HVAC System |  | 11.2d | 2017-08-08 | 2017-08-21 | CON-Z3-TL01-ME-110, CON-Z3-TL01-ME-100 | 57.6d | 12d | Mechanical Technician [26 h]; HVAC Crew [26 h] | 19,456.88 | 1.3.8.10 | CONS | CONS | ZONE-3 | REALM | Toilet-2 | 0 | 0 | 0.0255842733 | 6 | RPI - CONS | Z2 | LS12 | MECH |
| CON-Z3-Tl01-TC-70 |  | Testing & Pre-commissioning of Mechanical Works |  | 11.2d | 2017-08-22 | 2017-09-09 | CON-Z3-Tl01-TC-60 SS, CON-Z3-TL01-ME-120, CON-Z3-TL01-ME-190 | 45.6d | 42.6d | Mechanical Technician [52 h]; Specialist Works Crew [26 h] | 19,456.88 | 1.3.8.10 | CONS | CONS | ZONE-3 | REALM | Toilet-2 | 0 | 0 | 0.0511685254 | 6 | RPI - CONS | Z2 | LS12 | MECH |
| CON-Z3-Tl01-TC-80 |  | Testing & Pre-commissioning of Electrical Works |  | 12.8d | 2017-10-15 | 2017-10-29 | CON-Z3-TL01-ELE-30, CON-Z3-TL01-ELE-40, CON-Z3-TL01-ELE-50 FF | 3d | 0d | Electrician [1280 h]; LC Crew [52 h] | 38,913.76 | 1.3.8.10 | CONS | CONS | ZONE-3 | REALM | Toilet-2 | 0 | 0 | 0.0248538226 | 6 | RPI - CONS | Z2 | LS12 | ELEC |
| CON-Z3-Tl01-TC-90 |  | Completion of Toilet # 2 | milestone | 0d | 2017-10-29 | 2017-10-29 | CON-Z3-Tl01-TC-60, CON-Z3-TL01-EW-50, CON-Z3-Tl01-TC-50, CON-Z3-Tl01-TC-60 FF, CON-Z3-Tl01-TC-70, CON-Z3-Tl01-TC-80 | 3d | 2.8d |  |  | 1.3.8.10 | CONS | CONS | ZONE-3 | REALM | Toilet-2 | 0 | 0 | 0 | 6 | RPI - CONS | Z2 | LS12 | CIVIL |
|  | 2 | **Toilet Facility # 03** |  |  | 2017-07-17 | 2017-11-01 |  |  |  |  |  |  |  |  |  |  |  |  |  |  |  |  |  |  |  |
|  | 1 | **Civil Works** |  |  | 2017-07-17 | 2017-08-14 |  |  |  |  |  |  |  |  |  |  |  |  |  |  |  |  |  |  |  |
| CON-Z3-TL01-CW-40 |  | Start of Toilet Facility # 3 | milestone | 0d | 2017-07-17 | 2017-07-17 | CON-Z3-TL01-CW-20 FS+40d | 0.2d | 0d |  |  | 1.3.8.10 | CONS | CONS | ZONE-3 | REALM | Toilet-3 |  |  |  |  |  |  |  |  |
| CON-Z3-TL01-CW-50 |  | Remaining Work for Construction of Slab on Grade |  | 24d | 2017-07-17 | 2017-08-14 | CON-Z3-TL01-CW-40 | 0.2d | 0d | Steel Fixer [52 h]; Shuttering Carpenter [78 h]; Concrete Mason [78 h]; Common Labor / Helper [78 h] | 25,942.51 | 1.3.8.10 | CONS | CONS | ZONE-3 | REALM | Toilet-3 |  |  |  |  |  |  |  |  |
|  | 2 | **Architectural Works / Finishes** |  |  | 2017-07-26 | 2017-10-17 |  |  |  |  |  |  |  |  |  |  |  |  |  |  |  |  |  |  |  |
| CON-Z3-TL01-ARC-330 |  | Instalaltion of Moisture resistant gypsum board wall on metal stud/ framing system |  | 10d | 2017-07-26 | 2017-08-07 | CON-Z3-TL01-CW-50 SS+8d | 0.2d | 0d | Common Labor / Helper [52 h]; Scaffolder [52 h]; Plaster Mason [78 h]; Gypsum Walls & Ceiling Crew [52 h] | 15,133.13 | 1.3.8.10 | CONS | CONS | ZONE-3 | REALM | Toilet-3 |  |  |  |  |  |  |  |  |
| CON-Z3-TL01-ARC-340 |  | Instalaltion of Waterproofing Membrane for Wet Area |  | 8d | 2017-07-30 | 2017-08-08 | CON-Z3-TL01-ARC-330 SS+3d | 0.2d | 0d | Common Labor / Helper [52 h]; Water Proofing Crew [52 h]; Finishing Work Crew [52 h] | 6,053.25 | 1.3.8.10 | CONS | CONS | ZONE-3 | REALM | Toilet-3 |  |  |  |  |  |  |  |  |
| CON-Z3-TL01-ARC-350 |  | Installation of Ceramic Tiles for Floor |  | 25d | 2017-08-02 | 2017-09-05 | CON-Z3-TL01-ARC-340 SS+3d | 0.2d | 0d | Common Labor / Helper [104 h]; Block Mason [52 h]; Tiling Crew [52 h] | 30,266.26 | 1.3.8.10 | CONS | CONS | ZONE-3 | REALM | Toilet-3 |  |  |  |  |  |  |  |  |
| CON-Z3-TL01-ARC-360 |  | Installation of Ceramic Tiles for Walls |  | 20d | 2017-08-06 | 2017-08-29 | CON-Z3-TL01-ARC-350 SS+3d | 0.2d | 0d | Common Labor / Helper [104 h]; Block Mason [52 h]; Tiling Crew [52 h] | 30,266.26 | 1.3.8.10 | CONS | CONS | ZONE-3 | REALM | Toilet-3 |  |  |  |  |  |  |  |  |
| CON-Z3-TL01-ARC-370 |  | Installation of Ceramic Cover Base |  | 10d | 2017-08-09 | 2017-08-21 | CON-Z3-TL01-ARC-360 SS+3d | 0.2d | 0d | Block Mason [78 h]; Tiling Crew [52 h] | 9,079.88 | 1.3.8.10 | CONS | CONS | ZONE-3 | REALM | Toilet-3 |  |  |  |  |  |  |  |  |
| CON-Z3-TL01-ARC-380 |  | Installation of Moiture resistant gypsum board ceiling |  | 20d | 2017-08-13 | 2017-09-10 | CON-Z3-TL01-ARC-370 SS+3d | 0.2d | 0d | Common Labor / Helper [52 h]; Scaffolder [52 h]; Plaster Mason [78 h]; Gypsum Walls & Ceiling Crew [52 h] | 30,266.26 | 1.3.8.10 | CONS | CONS | ZONE-3 | REALM | Toilet-3 |  |  |  |  |  |  |  |  |
| CON-Z3-TL01-ARC-430 |  | Installation of Phenolic Toilet Partition |  | 10d | 2017-08-13 | 2017-08-24 | CON-Z3-TL01-ARC-380 SS | 21.2d | 21d | Common Labor / Helper [52 h]; Wood Works Crew [52 h] | 15,133.13 | 1.3.8.10 | CONS | CONS | ZONE-3 | REALM | Toilet-3 |  |  |  |  |  |  |  |  |
| CON-Z3-TL01-ARC-390 |  | Apply Textured paint finish for ceiling |  | 8d | 2017-09-10 | 2017-09-19 | CON-Z3-TL01-ARC-380 | 0.2d | 0d | Common Labor / Helper [26 h]; Scaffolder [52 h]; Painter [78 h]; Gypsum Walls & Ceiling Crew [52 h] | 9,079.88 | 1.3.8.10 | CONS | CONS | ZONE-3 | REALM | Toilet-3 |  |  |  |  |  |  |  |  |
| CON-Z3-TL01-ARC-400 |  | Installation of Roof Waterproofing System |  | 8d | 2017-09-19 | 2017-09-30 | CON-Z3-TL01-ARC-390 | 0.2d | 0d | Common Labor / Helper [52 h]; Water Proofing Crew [52 h]; Finishing Work Crew [52 h] | 15,133.13 | 1.3.8.10 | CONS | CONS | ZONE-3 | REALM | Toilet-3 |  |  |  |  |  |  |  |  |
| CON-Z3-TL01-ARC-410 |  | Internal Palstering and Painting |  | 20d | 2017-09-19 | 2017-10-14 | CON-Z3-TL01-ARC-340, CON-Z3-TL01-ARC-400 SS | 0.2d | 0d | Common Labor / Helper [26 h]; Scaffolder [52 h]; Painter [78 h] | 30,266.26 | 1.3.8.10 | CONS | CONS | ZONE-3 | REALM | Toilet-3 |  |  |  |  |  |  |  |  |
| CON-Z3-TL01-ARC-420 |  | External Painting |  | 5d | 2017-09-24 | 2017-09-30 | CON-Z3-TL01-ARC-410 SS+3d | 0.2d | 0d | Common Labor / Helper [26 h]; Scaffolder [52 h]; Painter [78 h] | 6,053.25 | 1.3.8.10 | CONS | CONS | ZONE-3 | REALM | Toilet-3 |  |  |  |  |  |  |  |  |
| CON-Z3-TL01-ARC-440 |  | Installation of Doors and Windows |  | 16d | 2017-09-24 | 2017-10-12 | CON-Z3-TL01-ARC-430, CON-Z3-TL01-ARC-420 SS | 0.2d | 0d | Shuttering Carpenter [52 h]; Common Labor / Helper [26 h] | 30,266.26 | 1.3.8.10 | CONS | CONS | ZONE-3 | REALM | Toilet-3 |  |  |  |  |  |  |  |  |
| CON-Z3-TL01-ARC-450 |  | Instalaltion of Cabinet and Counter Top and Glass blocks |  | 5d | 2017-09-24 | 2017-09-30 | CON-Z3-TL01-ARC-440 SS | 0.2d | 0d | Concrete Mason [52 h]; Common Labor / Helper [26 h] | 15,133.13 | 1.3.8.10 | CONS | CONS | ZONE-3 | REALM | Toilet-3 |  |  |  |  |  |  |  |  |
| CON-Z3-TL01-ARC-460 |  | Instalaltion of Toilet Fixures and Accessories |  | 20d | 2017-09-24 | 2017-10-17 | CON-Z3-TL01-ARC-450 SS | 0.2d | 0d | Common Labor / Helper [104 h] | 60,532.51 | 1.3.8.10 | CONS | CONS | ZONE-3 | REALM | Toilet-3 |  |  |  |  |  |  |  |  |

Notes:
- CON-Z3-TL01-EW-30: Expenses: (New Expense Item) 12106.5
- CON-Z3-TL01-EW-40: Expenses: (New Expense Item) 36319.5
- CON-Z3-TL01-EW-50: Expenses: (New Expense Item) 12106.5
- CON-Z3-Tl01-TC-50: Expenses: (New Expense Item) 51885
- CON-Z3-Tl01-TC-60: Expenses: (New Expense Item) 19456.9
- CON-Z3-Tl01-TC-70: Expenses: (New Expense Item) 19456.9
- CON-Z3-Tl01-TC-80: Expenses: (New Expense Item) 38913.8
- CON-Z3-TL01-CW-50: Expenses: (New Expense Item) 25942.5
- CON-Z3-TL01-ARC-330: Expenses: (New Expense Item) 15133.1
- CON-Z3-TL01-ARC-340: Expenses: (New Expense Item) 6053.25
- CON-Z3-TL01-ARC-350: Expenses: (New Expense Item) 30266.3
- CON-Z3-TL01-ARC-360: Expenses: (New Expense Item) 30266.3
- CON-Z3-TL01-ARC-370: Expenses: (New Expense Item) 9079.88
- CON-Z3-TL01-ARC-380: Expenses: (New Expense Item) 30266.3
- CON-Z3-TL01-ARC-430: Expenses: (New Expense Item) 15133.1
- CON-Z3-TL01-ARC-390: Expenses: (New Expense Item) 9079.88
- CON-Z3-TL01-ARC-400: Expenses: (New Expense Item) 15133.1
- CON-Z3-TL01-ARC-410: Expenses: (New Expense Item) 30266.3
- CON-Z3-TL01-ARC-420: Expenses: (New Expense Item) 6053.25
- CON-Z3-TL01-ARC-440: Expenses: (New Expense Item) 30266.3
- CON-Z3-TL01-ARC-450: Expenses: (New Expense Item) 15133.1
- CON-Z3-TL01-ARC-460: Expenses: (New Expense Item) 60532.5

| ID | WBS | Activity | Type | Duration | Start | Finish | Predecessors | Total float | Free float | Resources | Cost | RPI_P2 - BOQ ITEMS | RPI_P2 - CONSTRUCTION | RPI_P2 - PHASE | RPI_P2 - ZONES | RPI_P2 - AREAS | RPI_P2 - BUILDINGS | Activity Wt% | Weight % | Cost Wt | RPI - PHASE | RPI - CONSTRUCTION | RPI - ZONES | RPI - BUILDINGS | RPI - TYPE OF WORK |
| --- | --- | --- | --- | --- | --- | --- | --- | --- | --- | --- | --- | --- | --- | --- | --- | --- | --- | --- | --- | --- | --- | --- | --- | --- | --- |
|  | 3 | **Electrical Works** |  |  | 2017-09-24 | 2017-10-18 |  |  |  |  |  |  |  |  |  |  |  |  |  |  |  |  |  |  |  |
| CON-Z3-TL01-ELE-60 |  | Instalaltion of Eelectric Wiring Devices,Cables ,Disconnect Switches,Power Outlets,Junction Boxes and Accessories |  | 20d | 2017-09-24 | 2017-10-17 | CON-Z3-TL01-ARC-460 SS | 0.2d | 0d | Electrician [52 h]; LC Crew [52 h] | 77,827.52 | 1.3.8.10 | CONS | CONS | ZONE-3 | REALM | Toilet-3 |  |  |  |  |  |  |  |  |
| CON-Z3-TL01-ELE-70 |  | Installation of Internal and External Lighting Fixures and Accessories |  | 15d | 2017-09-30 | 2017-10-17 | CON-Z3-TL01-ELE-60 SS+5d | 1.8d | 1.6d | Electrician [52 h]; LC Crew [52 h] | 38,913.76 | 1.3.8.10 | CONS | CONS | ZONE-3 | REALM | Toilet-3 |  |  |  |  |  |  |  |  |
| CON-Z3-TL01-ELE-80 |  | Instalaltion of Water Heator |  | 1.6d | 2017-10-17 | 2017-10-18 | CON-Z3-TL01-ELE-60 | 0.2d | 0d | Electrician [52 h]; LC Crew [52 h] | 12,971.25 | 1.3.8.10 | CONS | CONS | ZONE-3 | REALM | Toilet-3 |  |  |  |  |  |  |  |  |
|  | 4 | **Mechanical Works** |  |  | 2017-07-17 | 2017-10-14 |  |  |  |  |  |  |  |  |  |  |  |  |  |  |  |  |  |  |  |
| CON-Z3-TL01-ME-240 |  | Instalation of Potable Water Supply Lines |  | 15d | 2017-07-17 | 2017-08-03 | CON-Z3-TL01-CW-40 | 5.6d | 0d | Plumber [78 h]; Common Labor / Helper [78 h] | 10,809.38 | 1.3.8.10 | CONS | CONS | ZONE-3 | REALM | Toilet-3 |  |  |  |  |  |  |  |  |
| CON-Z3-TL01-ME-260 |  | Installation of Hot Water Lines and Accessories |  | 15d | 2017-07-17 | 2017-08-03 | CON-Z3-TL01-ME-240 SS | 63.2d | 10d | Plumber [78 h]; Common Labor / Helper [52 h] | 10,809.38 | 1.3.8.10 | CONS | CONS | ZONE-3 | REALM | Toilet-3 |  |  |  |  |  |  |  |  |
| CON-Z3-TL01-ME-250 |  | Installation of Valves and Fittings for Potable Water Supply Ssytem |  | 10d | 2017-08-03 | 2017-08-15 | CON-Z3-TL01-ME-240 | 53.2d | 0d | Common Labor / Helper [26 h]; RTR Pipe Crew [26 h] | 21,618.76 | 1.3.8.10 | CONS | CONS | ZONE-3 | REALM | Toilet-3 |  |  |  |  |  |  |  |  |
| CON-Z3-TL01-ME-270 |  | Instalaltion of Sanitary Sewer Lines and Accessories |  | 20d | 2017-08-03 | 2017-08-27 | CON-Z3-TL01-ME-240 | 5.6d | 0d | Plumber [78 h]; Common Labor / Helper [52 h] | 21,618.76 | 1.3.8.10 | CONS | CONS | ZONE-3 | REALM | Toilet-3 |  |  |  |  |  |  |  |  |
| CON-Z3-TL01-ME-280 |  | Instalaltion of floor drains and clean out |  | 4d | 2017-08-27 | 2017-09-05 | CON-Z3-TL01-ME-270 | 5.6d | 0d | Plumber [52 h]; Common Labor / Helper [52 h] | 10,809.38 | 1.3.8.10 | CONS | CONS | ZONE-3 | REALM | Toilet-3 |  |  |  |  |  |  |  |  |
| CON-Z3-TL01-ME-200 |  | Installation of Gulvanized Steel duct |  | 12d | 2017-09-05 | 2017-09-19 | CON-Z3-TL01-ME-280, PR-Z3-GE-GE-238-0080 | 5.6d | 0d | HVAC Crew [26 h] | 43,237.51 | 1.3.8.10 | CONS | CONS | ZONE-3 | REALM | Toilet-3 |  |  |  |  |  |  |  |  |
| CON-Z3-TL01-ME-210 |  | Instalaltion of Exhaust Ceiling Diffuser |  | 8d | 2017-09-19 | 2017-09-30 | CON-Z3-TL01-ME-200 | 5.6d | 0d | Mechanical Technician [26 h]; Common Labor / Helper [26 h]; Gypsum Walls & Ceiling Crew [52 h] | 21,618.76 | 1.3.8.10 | CONS | CONS | ZONE-3 | REALM | Toilet-3 |  |  |  |  |  |  |  |  |
| CON-Z3-TL01-ME-220 |  | Installation of Exhaust Fans (EF-1,EF-2,EF-3,EF-4) |  | 4d | 2017-09-30 | 2017-10-04 | PR-Z3-EW-ME-63-0080, CON-Z3-TL01-ME-210 | 5.6d | 0d | Mechanical Technician [26 h]; Common Labor / Helper [52 h] | 21,618.76 | 1.3.8.10 | CONS | CONS | ZONE-3 | REALM | Toilet-3 |  |  |  |  |  |  |  |  |
| CON-Z3-TL01-ME-230 |  | Installation of Volume Control Dampers |  | 4d | 2017-10-04 | 2017-10-09 | CON-Z3-TL01-ME-220 | 5.6d | 0d | Electrician [200 h]; Common Labor / Helper [52 h] | 43,237.51 | 1.3.8.10 | CONS | CONS | ZONE-3 | REALM | Toilet-3 |  |  |  |  |  |  |  |  |
| CON-Z3-TL01-ME-290 |  | Instalaltion of Fire Extinguisher |  | 4d | 2017-10-09 | 2017-10-14 | CON-Z3-TL01-ME-230, CON-Z3-TL01-ME-220 | 5.6d | 0d | Mechanical Technician [26 h]; Common Labor / Helper [52 h] | 10,809.38 | 1.3.8.10 | CONS | CONS | ZONE-3 | REALM | Toilet-3 |  |  |  |  |  |  |  |  |
|  | 5 | **External Works** |  |  | 2017-09-30 | 2017-10-26 |  |  |  |  |  |  |  |  |  |  |  |  |  |  |  |  |  |  |  |
| CON-Z3-TL01-EW-60 |  | General Backfilling for External Works |  | 6.4d | 2017-09-30 | 2017-10-07 | CON-Z3-TL01-ARC-420 | 5.4d | 0d | Common Labor / Helper [78 h]; Operator - Loader [26 h]; Driver - Dump Truck [26 h]; Operator - Bobcat [26 h]; Operator - Roller-Compactor (2~10 Ton) [26 h]; Operator - Roller (25 Ton) [26 h]; Driver - Water Tanker [26 h]; Loader [28 h]; Dump Truck [28 h]; Bobcat [28 h]; Roller-Compactor (2~10 Ton) [28 h]; Roller-Compactor (25 Ton) [28 h]; Water Tanker [28 h] | 12,106.5 | 1.3.8.10 | CONS | CONS | ZONE-3 | REALM | Toilet-3 |  |  |  |  |  |  |  |  |
| CON-Z3-TL01-EW-70 |  | Installation of Side workway (Apron around the building) |  | 12d | 2017-10-07 | 2017-10-21 | CON-Z3-TL01-EW-60 | 5.4d | 0d | Steel Fixer [78 h]; Shuttering Carpenter [78 h]; Concrete Mason [78 h]; Common Labor / Helper [52 h] | 36,319.51 | 1.3.8.10 | CONS | CONS | ZONE-3 | REALM | Toilet-3 |  |  |  |  |  |  |  |  |
| CON-Z3-TL01-EW-80 |  | Instalaltion of Sign Boards |  | 5d | 2017-10-21 | 2017-10-26 | CON-Z3-TL01-EW-70 | 5.4d | 5.2d | Shuttering Carpenter [26 h]; Common Labor / Helper [52 h] | 12,106.5 | 1.3.8.10 | CONS | CONS | ZONE-3 | REALM | Toilet-3 |  |  |  |  |  |  |  |  |
|  | 6 | **Testing & Pre-Commissioning** |  |  | 2017-08-15 | 2017-11-01 |  |  |  |  |  |  |  |  |  |  |  |  |  |  |  |  |  |  |  |
| CON-Z3-Tl01-TC-100 |  | Hydro Testing - Plumbing Works |  | 9.6d | 2017-08-15 | 2017-08-26 | CON-Z3-TL01-ME-240, CON-Z3-TL01-ME-250, CON-Z3-TL01-ME-260 | 53.2d | 53d | Plumber [26 h]; Common Labor / Helper [52 h]; Driver - Water Tanker [26 h] | 51,885.01 | 1.3.8.10 | CONS | CONS | ZONE-3 | REALM | Toilet-3 | 0 | 0 | 0.0085280982 | 6 | RPI - CONS | Z2 | LS12 | MECH |
| CON-Z3-Tl01-TC-110 |  | Testing & Balancing of HVAC System |  | 11.2d | 2017-09-30 | 2017-10-12 | CON-Z3-TL01-ME-200, CON-Z3-TL01-ME-210 | 17.6d | 12d | Mechanical Technician [26 h]; HVAC Crew [26 h] | 19,456.88 | 1.3.8.10 | CONS | CONS | ZONE-3 | REALM | Toilet-3 | 0 | 0 | 0.0255842733 | 6 | RPI - CONS | Z2 | LS12 | MECH |
| CON-Z3-Tl01-TC-120 |  | Testing & Pre-commissioning of Mechanical Works |  | 11.2d | 2017-10-14 | 2017-10-26 | CON-Z3-TL01-ME-290, CON-Z3-TL01-ME-220, CON-Z3-Tl01-TC-110 SS | 5.6d | 5.4d | Mechanical Technician [560 h]; Specialist Works Crew [224 h] | 19,456.88 | 1.3.8.10 | CONS | CONS | ZONE-3 | REALM | Toilet-3 | 0 | 0 | 0.0511685254 | 6 | RPI - CONS | Z2 | LS12 | MECH |
| CON-Z3-Tl01-TC-130 |  | Testing & Pre-commissioning of Electrical Works |  | 12d | 2017-10-18 | 2017-11-01 | CON-Z3-TL01-ELE-60, CON-Z3-TL01-ELE-70, CON-Z3-TL01-ELE-80 | 0.2d | 0d | Electrician [1800 h]; LC Crew [600 h] | 38,913.76 | 1.3.8.10 | CONS | CONS | ZONE-3 | REALM | Toilet-3 | 0 | 0 | 0.0248538226 | 6 | RPI - CONS | Z2 | LS12 | ELEC |
| CON-Z3-Tl01-TC-140 |  | Completion of Toilet # 3 | milestone | 0d | 2017-11-01 | 2017-11-01 | CON-Z3-Tl01-TC-120, CON-Z3-Tl01-TC-110 FF, CON-Z3-TL01-EW-80, CON-Z3-Tl01-TC-100, CON-Z3-Tl01-TC-110, CON-Z3-Tl01-TC-130 | 0.2d | 0d |  |  | 1.3.8.10 | CONS | CONS | ZONE-3 | REALM | Toilet-3 | 0 | 0 | 0 | 6 | RPI - CONS | Z2 | LS12 | CIVIL |

Notes:
- CON-Z3-TL01-ELE-60: Expenses: (New Expense Item) 77827.5
- CON-Z3-TL01-ELE-70: Expenses: (New Expense Item) 38913.8
- CON-Z3-TL01-ELE-80: Expenses: (New Expense Item) 12971.2
- CON-Z3-TL01-ME-240: Expenses: (New Expense Item) 10809.4
- CON-Z3-TL01-ME-260: Expenses: (New Expense Item) 10809.4
- CON-Z3-TL01-ME-250: Expenses: (New Expense Item) 21618.8
- CON-Z3-TL01-ME-270: Expenses: (New Expense Item) 21618.8
- CON-Z3-TL01-ME-280: Expenses: (New Expense Item) 10809.4
- CON-Z3-TL01-ME-200: Expenses: (New Expense Item) 43237.5
- CON-Z3-TL01-ME-210: Expenses: (New Expense Item) 21618.8
- CON-Z3-TL01-ME-220: Expenses: (New Expense Item) 21618.8
- CON-Z3-TL01-ME-230: Expenses: (New Expense Item) 43237.5
- CON-Z3-TL01-ME-290: Expenses: (New Expense Item) 10809.4
- CON-Z3-TL01-EW-60: Expenses: (New Expense Item) 12106.5
- CON-Z3-TL01-EW-70: Expenses: (New Expense Item) 36319.5
- CON-Z3-TL01-EW-80: Expenses: (New Expense Item) 12106.5
- CON-Z3-Tl01-TC-100: Expenses: (New Expense Item) 51885
- CON-Z3-Tl01-TC-110: Expenses: (New Expense Item) 19456.9
- CON-Z3-Tl01-TC-120: Expenses: (New Expense Item) 19456.9
- CON-Z3-Tl01-TC-130: Expenses: (New Expense Item) 38913.8

| ID | WBS | Activity | Type | Duration | Start | Finish | Predecessors | Total float | Free float | Resources | Cost | RPI_P2 - BOQ ITEMS | RPI_P2 - CONSTRUCTION | RPI_P2 - PHASE | RPI_P2 - ZONES | RPI_P2 - AREAS | RPI_P2 - BUILDINGS |
| --- | --- | --- | --- | --- | --- | --- | --- | --- | --- | --- | --- | --- | --- | --- | --- | --- | --- |
|  | 2 | **Snack Bars (O4 No.s)** |  |  | 2017-02-05 | 2017-10-09 |  |  |  |  |  |  |  |  |  |  |  |
|  | 1 | **Snack Bar # 01** |  |  | 2017-02-05 | 2017-08-15 |  |  |  |  |  |  |  |  |  |  |  |
|  | 1 | **Civil / Structural Works** |  |  | 2017-02-05 | 2017-02-28 |  |  |  |  |  |  |  |  |  |  |  |
| CON-Z3-SB-01-CW-0010 |  | Start of Snack Bar # 01 | milestone | 0d | 2017-02-05 | 2017-02-05 | CON-CON-CON-CON-0010 FS+150d | 97.8d | 0d |  |  | 1.3.8.20 | CONS | CONS | ZONE-3 | REALM | Snack-1 |
| CON-Z3-SB-01-CW-0020 |  | Backfilling around the building |  | 8d | 2017-02-05 | 2017-02-14 | CON-Z3-SB-01-CW-0010 | 139.8d | 0d | Common Labor / Helper [78 h]; Operator - Loader [26 h]; Driver - Dump Truck [26 h]; Operator - Bobcat [26 h]; Operator - Roller-Compactor (2~10 Ton) [26 h]; Operator - Roller (25 Ton) [26 h]; Driver - Water Tanker [26 h]; Loader [28 h]; Dump Truck [28 h]; Bobcat [28 h]; Roller-Compactor (2~10 Ton) [28 h]; Roller-Compactor (25 Ton) [28 h]; Water Tanker [28 h] | 1,937.37 | 1.3.8.20 | CONS | CONS | ZONE-3 | REALM | Snack-1 |
| CON-Z3-SB-01-CW-0030 |  | Installation of Reinforced Concrete Slab on Garde |  | 12d | 2017-02-14 | 2017-02-28 | CON-Z3-SB-01-CW-0020 | 139.8d | 0d | Steel Fixer [52 h]; Shuttering Carpenter [78 h]; Concrete Mason [78 h]; Common Labor / Helper [78 h] | 1,291.58 | 1.3.8.20 | CONS | CONS | ZONE-3 | REALM | Snack-1 |
|  | 2 | **Architectural Works / Finishes** |  |  | 2017-02-28 | 2017-06-20 |  |  |  |  |  |  |  |  |  |  |  |
| CON-Z3-SB-01-AR-0010 |  | External Plastering |  | 4d | 2017-02-28 | 2017-03-05 | CON-Z3-SB-01-CW-0030 | 139.8d | 0d | Concrete Mason [78 h]; Common Labor / Helper [26 h]; Scaffolder [26 h]; Finishing Work Crew [52 h] | 516.63 | 1.3.8.20 | CONS | CONS | ZONE-3 | REALM | Snack-1 |
| CON-Z3-SB-01-AR-0020 |  | Internal Plastering |  | 4d | 2017-03-05 | 2017-03-09 | CON-Z3-SB-01-AR-0010 | 139.8d | 0d | Concrete Mason [78 h]; Common Labor / Helper [26 h]; Scaffolder [26 h]; Finishing Work Crew [52 h] | 1,808.21 | 1.3.8.20 | CONS | CONS | ZONE-3 | REALM | Snack-1 |
| CON-Z3-SB-01-AR-0030 |  | Installation of Waterproofing System on the sloped roof of bar |  | 8d | 2017-03-09 | 2017-03-19 | CON-Z3-SB-01-AR-0020 | 139.8d | 0d | Common Labor / Helper [52 h]; Water Proofing Crew [52 h]; Finishing Work Crew [52 h] | 1,291.58 | 1.3.8.20 | CONS | CONS | ZONE-3 | REALM | Snack-1 |
| CON-Z3-SB-01-AR-0100 |  | Installation of Moiture resistant gypsum board ceiling |  | 12d | 2017-03-09 | 2017-03-23 | CON-Z3-SB-01-AR-0020 | 183.8d | 44d | Common Labor / Helper [52 h]; Scaffolder [52 h]; Plaster Mason [78 h]; Gypsum Walls & Ceiling Crew [52 h] | 2,583.15 | 1.3.8.20 | CONS | CONS | ZONE-3 | REALM | Snack-1 |
| CON-Z3-SB-01-AR-0050 |  | Installation of Concrete Topping |  | 4d | 2017-03-19 | 2017-03-23 | CON-Z3-SB-01-AR-0020, CON-Z3-SB-01-AR-0030 | 139.8d | 0d | Concrete Mason [78 h] | 1,291.58 | 1.3.8.20 | CONS | CONS | ZONE-3 | REALM | Snack-1 |
| CON-Z3-SB-01-AR-0060 |  | Installation of Ceramic tiles for floors |  | 16d | 2017-03-23 | 2017-04-11 | CON-Z3-SB-01-AR-0050 | 139.8d | 0d | Common Labor / Helper [104 h]; Block Mason [52 h]; Tiling Crew [52 h] | 2,583.15 | 1.3.8.20 | CONS | CONS | ZONE-3 | REALM | Snack-1 |
| CON-Z3-SB-01-AR-0070 |  | Installation of Ceramic Floor walls |  | 12d | 2017-04-11 | 2017-04-25 | CON-Z3-SB-01-AR-0060 | 139.8d | 0d | Block Mason [78 h]; Tiling Crew [52 h] | 2,583.15 | 1.3.8.20 | CONS | CONS | ZONE-3 | REALM | Snack-1 |
| CON-Z3-SB-01-AR-0080 |  | External Painting |  | 8d | 2017-04-25 | 2017-05-04 | CON-Z3-SB-01-AR-0070 | 139.8d | 0d | Common Labor / Helper [26 h]; Scaffolder [52 h]; Painter [78 h] | 1,291.58 | 1.3.8.20 | CONS | CONS | ZONE-3 | REALM | Snack-1 |
| CON-Z3-SB-01-AR-0090 |  | Internal Painting |  | 8d | 2017-05-04 | 2017-05-14 | CON-Z3-SB-01-AR-0080 | 139.8d | 0d | Common Labor / Helper [26 h]; Scaffolder [52 h]; Painter [78 h] | 2,583.15 | 1.3.8.20 | CONS | CONS | ZONE-3 | REALM | Snack-1 |
| CON-Z3-SB-01-AR-0110 |  | Apply Textured paint finish for ceiling |  | 4d | 2017-05-14 | 2017-05-18 | CON-Z3-SB-01-AR-0090, CON-Z3-SB-01-AR-0100 | 139.8d | 0d | Common Labor / Helper [26 h]; Scaffolder [52 h]; Painter [78 h]; Gypsum Walls & Ceiling Crew [52 h] | 1,291.58 | 1.3.8.20 | CONS | CONS | ZONE-3 | REALM | Snack-1 |
| CON-Z3-SB-01-AR-0120 |  | Installation of Doors and Windows |  | 8d | 2017-05-18 | 2017-05-28 | CON-Z3-SB-01-AR-0110 | 139.8d | 0d | Shuttering Carpenter [52 h]; Common Labor / Helper [26 h] | 2,583.15 | 1.3.8.20 | CONS | CONS | ZONE-3 | REALM | Snack-1 |
| CON-Z3-SB-01-AR-0130 |  | Installation of Composit Wood Trellis |  | 12d | 2017-05-28 | 2017-06-11 | PR-Z3-GE-GE-220-0080, CON-Z3-SB-01-AR-0120 | 139.8d | 0d | Shuttering Carpenter [52 h]; Common Labor / Helper [78 h]; Scaffolder [52 h]; Wood Works Crew [52 h] | 3,874.73 | 1.3.8.20 | CONS | CONS | ZONE-3 | REALM | Snack-1 |
| CON-Z3-SB-01-AR-0140 |  | Installation of Telephonic Cabinet |  | 4d | 2017-06-11 | 2017-06-15 | CON-Z3-SB-01-AR-0130 | 139.8d | 0d | Common Labor / Helper [52 h]; Wood Works Crew [52 h] | 774.95 | 1.3.8.20 | CONS | CONS | ZONE-3 | REALM | Snack-1 |
| CON-Z3-SB-01-AR-0150 |  | Installation of Laminated Wall Cabinet |  | 4d | 2017-06-15 | 2017-06-20 | CON-Z3-SB-01-AR-0140, PR-Z3-GE-GE-229-0080 | 139.8d | 0d | Common Labor / Helper [52 h]; Wood Works Crew [52 h] | 774.95 | 1.3.8.20 | CONS | CONS | ZONE-3 | REALM | Snack-1 |
|  | 3 | **Electrical Works** |  |  | 2017-06-20 | 2017-08-01 |  |  |  |  |  |  |  |  |  |  |  |
| CON-Z3-SB-01-EW-0010 |  | Instalaltion of Eelectric Wiring Devices,Cables and Accessories |  | 12d | 2017-06-20 | 2017-07-09 | CON-Z3-SB-01-AR-0150 | 139.8d | 0d | Electrician [78 h]; LC Crew [52 h] | 6,780.78 | 1.3.8.20 | CONS | CONS | ZONE-3 | REALM | Snack-1 |
| CON-Z3-SB-01-EW-0020 |  | Installation of Internal and External Lighting Fixures and Accessories |  | 20d | 2017-07-09 | 2017-08-01 | CON-Z3-SB-01-EW-0010 | 139.8d | 0d | Electrician [78 h]; LC Crew [52 h] | 2,906.05 | 1.3.8.20 | CONS | CONS | ZONE-3 | REALM | Snack-1 |

Notes:
- CON-Z3-SB-01-CW-0020: Expenses: (New Expense Item) 1937.37
- CON-Z3-SB-01-CW-0030: Expenses: (New Expense Item) 1291.58
- CON-Z3-SB-01-AR-0010: Expenses: (New Expense Item) 516.63
- CON-Z3-SB-01-AR-0020: Expenses: (New Expense Item) 1808.21
- CON-Z3-SB-01-AR-0030: Expenses: (New Expense Item) 1291.58
- CON-Z3-SB-01-AR-0100: Expenses: (New Expense Item) 2583.15
- CON-Z3-SB-01-AR-0050: Expenses: (New Expense Item) 1291.58
- CON-Z3-SB-01-AR-0060: Expenses: (New Expense Item) 2583.15
- CON-Z3-SB-01-AR-0070: Expenses: (New Expense Item) 2583.15
- CON-Z3-SB-01-AR-0080: Expenses: (New Expense Item) 1291.58
- CON-Z3-SB-01-AR-0090: Expenses: (New Expense Item) 2583.15
- CON-Z3-SB-01-AR-0110: Expenses: (New Expense Item) 1291.58
- CON-Z3-SB-01-AR-0120: Expenses: (New Expense Item) 2583.15
- CON-Z3-SB-01-AR-0130: Expenses: (New Expense Item) 3874.73
- CON-Z3-SB-01-AR-0140: Expenses: (New Expense Item) 774.95
- CON-Z3-SB-01-AR-0150: Expenses: (New Expense Item) 774.95
- CON-Z3-SB-01-EW-0010: Expenses: (New Expense Item) 6780.78
- CON-Z3-SB-01-EW-0020: Expenses: (New Expense Item) 2906.05

| ID | WBS | Activity | Type | Duration | Start | Finish | Predecessors | Total float | Free float | Resources | Cost | RPI_P2 - BOQ ITEMS | RPI_P2 - CONSTRUCTION | RPI_P2 - PHASE | RPI_P2 - ZONES | RPI_P2 - AREAS | RPI_P2 - BUILDINGS |
| --- | --- | --- | --- | --- | --- | --- | --- | --- | --- | --- | --- | --- | --- | --- | --- | --- | --- |
|  | 4 | **Mechanical Works** |  |  | 2017-02-28 | 2017-07-13 |  |  |  |  |  |  |  |  |  |  |  |
| CON-Z3-SB-01-ME-0010 |  | Installation of Water Supply System (Pipes,Fittings and Accessories) |  | 16d | 2017-02-28 | 2017-03-19 | CON-Z3-SB-01-CW-0030 | 223.8d | 0d | Plumber [52 h]; Common Labor / Helper [52 h] | 4,843.41 | 1.3.8.20 | CONS | CONS | ZONE-3 | REALM | Snack-1 |
| CON-Z3-SB-01-ME-0020 |  | Installation of Sewer System |  | 16d | 2017-03-19 | 2017-04-06 | CON-Z3-SB-01-ME-0010 | 223.8d | 0d | Plumber [52 h]; Common Labor / Helper [52 h] | 4,843.41 | 1.3.8.20 | CONS | CONS | ZONE-3 | REALM | Snack-1 |
| CON-Z3-SB-01-ME-0040 |  | Installation of Tie-in Connection for Water Supply |  | 4d | 2017-03-19 | 2017-03-23 | CON-Z3-SB-01-ME-0010 | 243.8d | 20d | Plumber [52 h]; Common Labor / Helper [52 h] | 807.24 | 1.3.8.20 | CONS | CONS | ZONE-3 | REALM | Snack-1 |
| CON-Z3-SB-01-ME-0030 |  | Instalaltion of Floor Drain and Cleanout |  | 4d | 2017-04-06 | 2017-04-11 | CON-Z3-SB-01-ME-0020 | 223.8d | 0d | Plumber [52 h]; Common Labor / Helper [52 h] | 1,614.47 | 1.3.8.20 | CONS | CONS | ZONE-3 | REALM | Snack-1 |
| CON-Z3-SB-01-ME-0050 |  | Installation of Tie-in Connection for Drainage |  | 4d | 2017-04-11 | 2017-04-16 | CON-Z3-SB-01-ME-0020, CON-Z3-SB-01-ME-0030 | 223.8d | 0d | Plumber [52 h]; Common Labor / Helper [52 h] | 807.24 | 1.3.8.20 | CONS | CONS | ZONE-3 | REALM | Snack-1 |
| CON-Z3-SB-01-ME-0060 |  | Installation of Fire Extinguisher (FE-2) |  | 1.6d | 2017-07-09 | 2017-07-10 | CON-Z3-SB-01-EW-0020 SS | 155.8d | 0d | Common Labor / Helper [52 h] | 1,614.47 | 1.3.8.20 | CONS | CONS | ZONE-3 | REALM | Snack-1 |
| CON-Z3-SB-01-ME-0070 |  | Installation of Window AC (1.5 ton) |  | 2.4d | 2017-07-10 | 2017-07-13 | PR-Z3-GE-GE-240-0080, CON-Z3-SB-01-ME-0060 | 155.8d | 0d | Mechanical Technician [26 h]; HVAC Crew [26 h] | 1,614.47 | 1.3.8.20 | CONS | CONS | ZONE-3 | REALM | Snack-1 |
|  | 6 | **Testing & Pre-Commissioning** |  |  | 2017-04-16 | 2017-08-15 |  |  |  |  |  |  |  |  |  |  |  |
| CON-Z3-SB-01-TC-0010 |  | Hydro Testing - Plumbing Works |  | 12d | 2017-04-16 | 2017-04-30 | CON-Z3-SB-01-ME-0020, CON-Z3-SB-01-ME-0050, CON-Z3-SB-01-ME-0040, CON-Z3-SB-01-ME-0010 | 223.8d | 84d | Plumber [26 h]; Common Labor / Helper [52 h]; Driver - Water Tanker [26 h] | 4,843.41 | 1.3.8.20 | CONS | CONS | ZONE-3 | REALM | Snack-1 |
| CON-Z3-SB-01-TC-0020 |  | Testing & Pre-commissioning of Mechanical Works |  | 8d | 2017-07-13 | 2017-07-23 | CON-Z3-SB-01-ME-0060, CON-Z3-SB-01-ME-0070 | 155.8d | 16d | Mechanical Technician [52 h]; Specialist Works Crew [26 h] | 1,937.37 | 1.3.8.20 | CONS | CONS | ZONE-3 | REALM | Snack-1 |
| CON-Z3-SB-01-TC-0030 |  | Testing & Pre-commissioning of Electrical Works |  | 8d | 2017-08-01 | 2017-08-10 | CON-Z3-SB-01-EW-0010, CON-Z3-SB-01-EW-0020 | 139.8d | 0d | Electrician [78 h]; LC Crew [52 h] | 2,906.05 | 1.3.8.20 | CONS | CONS | ZONE-3 | REALM | Snack-1 |
| CON-Z3-SB-01-TC-0040 |  | Completion of Snack Bar # 1 |  | 4d | 2017-08-10 | 2017-08-15 | CON-Z3-SB-01-TC-0020, CON-Z3-SB-01-TC-0010, CON-Z3-SB-01-TC-0030 | 139.8d |  |  |  | 1.3.8.20 | CONS | CONS | ZONE-3 | REALM | Snack-1 |
|  | 5 | **Snack Bar # 02** |  |  | 2017-02-19 | 2017-08-29 |  |  |  |  |  |  |  |  |  |  |  |
|  | 1 | **Civil / Structural Works** |  |  | 2017-02-19 | 2017-03-14 |  |  |  |  |  |  |  |  |  |  |  |
| CON-Z3-SB-02-CW-0010 |  | Start of Snack Bar # 02 | milestone | 0d | 2017-02-19 | 2017-02-19 | CON-Z3-SB-01-CW-0010 SS+12d | 97.8d | 0d |  |  | 1.3.8.20 | CONS | CONS | ZONE-3 | REALM | Snack-2 |
| CON-Z3-SB-02-CW-0020 |  | Backfilling around the building |  | 8d | 2017-02-19 | 2017-02-28 | CON-Z3-SB-02-CW-0010 | 127.8d | 0d | Common Labor / Helper [78 h]; Operator - Loader [26 h]; Driver - Dump Truck [26 h]; Operator - Bobcat [26 h]; Operator - Roller-Compactor (2~10 Ton) [26 h]; Operator - Roller (25 Ton) [26 h]; Driver - Water Tanker [26 h]; Loader [28 h]; Dump Truck [28 h]; Bobcat [28 h]; Roller-Compactor (2~10 Ton) [28 h]; Roller-Compactor (25 Ton) [28 h]; Water Tanker [28 h] | 1,937.37 | 1.3.8.20 | CONS | CONS | ZONE-3 | REALM | Snack-2 |
| CON-Z3-SB-02-CW-0030 |  | Installation of Reinforced Concrete Slab on Garde |  | 12d | 2017-02-28 | 2017-03-14 | CON-Z3-SB-02-CW-0020 | 127.8d | 0d | Steel Fixer [52 h]; Shuttering Carpenter [78 h]; Concrete Mason [78 h]; Common Labor / Helper [78 h] | 1,291.58 | 1.3.8.20 | CONS | CONS | ZONE-3 | REALM | Snack-2 |
|  | 2 | **Architectural Works / Finishes** |  |  | 2017-03-14 | 2017-07-09 |  |  |  |  |  |  |  |  |  |  |  |
| CON-Z3-SB-02-AR-0010 |  | External Plastering |  | 4d | 2017-03-14 | 2017-03-19 | CON-Z3-SB-02-CW-0030 | 127.8d | 0d | Concrete Mason [78 h]; Common Labor / Helper [26 h]; Scaffolder [26 h]; Finishing Work Crew [52 h] | 516.63 | 1.3.8.20 | CONS | CONS | ZONE-3 | REALM | Snack-2 |
| CON-Z3-SB-02-AR-0020 |  | Internal Plastering |  | 4d | 2017-03-19 | 2017-03-23 | CON-Z3-SB-02-AR-0010 | 127.8d | 0d | Concrete Mason [78 h]; Common Labor / Helper [26 h]; Scaffolder [26 h]; Finishing Work Crew [52 h] | 1,808.21 | 1.3.8.20 | CONS | CONS | ZONE-3 | REALM | Snack-2 |
| CON-Z3-SB-02-AR-0030 |  | Installation of Waterproofing System on the sloped roof of bar |  | 8d | 2017-03-23 | 2017-04-02 | CON-Z3-SB-02-AR-0020 | 127.8d | 0d | Common Labor / Helper [52 h]; Water Proofing Crew [52 h]; Finishing Work Crew [52 h] | 1,291.58 | 1.3.8.20 | CONS | CONS | ZONE-3 | REALM | Snack-2 |
| CON-Z3-SB-02-AR-0090 |  | Installation of Moiture resistant gypsum board ceiling |  | 12d | 2017-03-23 | 2017-04-06 | CON-Z3-SB-02-AR-0020 | 171.8d | 44d | Common Labor / Helper [52 h]; Scaffolder [52 h]; Plaster Mason [78 h]; Gypsum Walls & Ceiling Crew [52 h] | 2,583.15 | 1.3.8.20 | CONS | CONS | ZONE-3 | REALM | Snack-2 |
| CON-Z3-SB-02-AR-0040 |  | Installation of Concrete Topping |  | 4d | 2017-04-02 | 2017-04-06 | CON-Z3-SB-02-AR-0020, CON-Z3-SB-02-AR-0030 | 127.8d | 0d | Concrete Mason [78 h] | 1,291.58 | 1.3.8.20 | CONS | CONS | ZONE-3 | REALM | Snack-2 |
| CON-Z3-SB-02-AR-0050 |  | Installation of Ceramic tiles for floors |  | 16d | 2017-04-06 | 2017-04-25 | CON-Z3-SB-02-AR-0040 | 127.8d | 0d | Common Labor / Helper [104 h]; Block Mason [52 h]; Tiling Crew [52 h] | 2,583.15 | 1.3.8.20 | CONS | CONS | ZONE-3 | REALM | Snack-2 |
| CON-Z3-SB-02-AR-0060 |  | Installation of Ceramic Floor walls |  | 12d | 2017-04-25 | 2017-05-09 | CON-Z3-SB-02-AR-0050 | 127.8d | 0d | Block Mason [78 h]; Tiling Crew [52 h] | 2,583.15 | 1.3.8.20 | CONS | CONS | ZONE-3 | REALM | Snack-2 |
| CON-Z3-SB-02-AR-0070 |  | External Painting |  | 8d | 2017-05-09 | 2017-05-18 | CON-Z3-SB-02-AR-0060 | 127.8d | 0d | Common Labor / Helper [26 h]; Scaffolder [52 h]; Painter [78 h] | 1,291.58 | 1.3.8.20 | CONS | CONS | ZONE-3 | REALM | Snack-2 |
| CON-Z3-SB-02-AR-0080 |  | Internal Painting |  | 8d | 2017-05-18 | 2017-05-28 | CON-Z3-SB-02-AR-0070 | 127.8d | 0d | Common Labor / Helper [26 h]; Scaffolder [52 h]; Painter [78 h] | 2,583.15 | 1.3.8.20 | CONS | CONS | ZONE-3 | REALM | Snack-2 |
| CON-Z3-SB-02-AR-0100 |  | Apply Textured paint finish for ceiling |  | 4d | 2017-05-28 | 2017-06-01 | CON-Z3-SB-02-AR-0080, CON-Z3-SB-02-AR-0090 | 127.8d | 0d | Common Labor / Helper [26 h]; Scaffolder [52 h]; Painter [78 h]; Gypsum Walls & Ceiling Crew [52 h] | 1,291.58 | 1.3.8.20 | CONS | CONS | ZONE-3 | REALM | Snack-2 |
| CON-Z3-SB-02-AR-0110 |  | Installation of Doors and Windows |  | 8d | 2017-06-01 | 2017-06-11 | CON-Z3-SB-02-AR-0100 | 127.8d | 0d | Shuttering Carpenter [52 h]; Common Labor / Helper [26 h] | 2,583.15 | 1.3.8.20 | CONS | CONS | ZONE-3 | REALM | Snack-2 |
| CON-Z3-SB-02-AR-0120 |  | Installation of Composit Wood Trellis |  | 12d | 2017-06-11 | 2017-06-25 | CON-Z3-SB-02-AR-0110 | 127.8d | 0d | Shuttering Carpenter [52 h]; Common Labor / Helper [78 h]; Scaffolder [52 h]; Wood Works Crew [52 h] | 3,874.73 | 1.3.8.20 | CONS | CONS | ZONE-3 | REALM | Snack-2 |
| CON-Z3-SB-02-AR-0130 |  | Installation of Telephonic Cabinet |  | 4d | 2017-06-25 | 2017-07-04 | CON-Z3-SB-02-AR-0120 | 127.8d | 0d | Common Labor / Helper [52 h]; Wood Works Crew [52 h] | 774.95 | 1.3.8.20 | CONS | CONS | ZONE-3 | REALM | Snack-2 |
| CON-Z3-SB-02-AR-0140 |  | Installation of Laminated Wall Cabinet |  | 4d | 2017-07-04 | 2017-07-09 | CON-Z3-SB-02-AR-0130 | 127.8d | 0d | Common Labor / Helper [52 h]; Wood Works Crew [52 h] | 774.95 | 1.3.8.20 | CONS | CONS | ZONE-3 | REALM | Snack-2 |

Notes:
- CON-Z3-SB-01-ME-0010: Expenses: (New Expense Item) 4843.41
- CON-Z3-SB-01-ME-0020: Expenses: (New Expense Item) 4843.41
- CON-Z3-SB-01-ME-0040: Expenses: (New Expense Item) 807.24
- CON-Z3-SB-01-ME-0030: Expenses: (New Expense Item) 1614.47
- CON-Z3-SB-01-ME-0050: Expenses: (New Expense Item) 807.24
- CON-Z3-SB-01-ME-0060: Expenses: (New Expense Item) 1614.47
- CON-Z3-SB-01-ME-0070: Expenses: (New Expense Item) 1614.47
- CON-Z3-SB-01-TC-0010: Expenses: (New Expense Item) 4843.41
- CON-Z3-SB-01-TC-0020: Expenses: (New Expense Item) 1937.37
- CON-Z3-SB-01-TC-0030: Expenses: (New Expense Item) 2906.05
- CON-Z3-SB-02-CW-0020: Expenses: (New Expense Item) 1937.37
- CON-Z3-SB-02-CW-0030: Expenses: (New Expense Item) 1291.58
- CON-Z3-SB-02-AR-0010: Expenses: (New Expense Item) 516.63
- CON-Z3-SB-02-AR-0020: Expenses: (New Expense Item) 1808.21
- CON-Z3-SB-02-AR-0030: Expenses: (New Expense Item) 1291.58
- CON-Z3-SB-02-AR-0090: Expenses: (New Expense Item) 2583.15
- CON-Z3-SB-02-AR-0040: Expenses: (New Expense Item) 1291.58
- CON-Z3-SB-02-AR-0050: Expenses: (New Expense Item) 2583.15
- CON-Z3-SB-02-AR-0060: Expenses: (New Expense Item) 2583.15
- CON-Z3-SB-02-AR-0070: Expenses: (New Expense Item) 1291.58
- CON-Z3-SB-02-AR-0080: Expenses: (New Expense Item) 2583.15
- CON-Z3-SB-02-AR-0100: Expenses: (New Expense Item) 1291.58
- CON-Z3-SB-02-AR-0110: Expenses: (New Expense Item) 2583.15
- CON-Z3-SB-02-AR-0120: Expenses: (New Expense Item) 3874.73
- CON-Z3-SB-02-AR-0130: Expenses: (New Expense Item) 774.95
- CON-Z3-SB-02-AR-0140: Expenses: (New Expense Item) 774.95

| ID | WBS | Activity | Type | Duration | Start | Finish | Predecessors | Total float | Free float | Resources | Cost | RPI_P2 - BOQ ITEMS | RPI_P2 - CONSTRUCTION | RPI_P2 - PHASE | RPI_P2 - ZONES | RPI_P2 - AREAS | RPI_P2 - BUILDINGS |
| --- | --- | --- | --- | --- | --- | --- | --- | --- | --- | --- | --- | --- | --- | --- | --- | --- | --- |
|  | 3 | **Electrical Works** |  |  | 2017-07-09 | 2017-08-15 |  |  |  |  |  |  |  |  |  |  |  |
| CON-Z3-SB-02-EW-0010 |  | Instalaltion of Eelectric Wiring Devices,Cables and Accessories |  | 12d | 2017-07-09 | 2017-07-23 | CON-Z3-SB-02-AR-0140 | 127.8d | 0d | Electrician [78 h]; LC Crew [52 h] | 6,780.78 | 1.3.8.20 | CONS | CONS | ZONE-3 | REALM | Snack-2 |
| CON-Z3-SB-02-EW-0020 |  | Installation of Internal and External Lighting Fixures and Accessories |  | 20d | 2017-07-23 | 2017-08-15 | CON-Z3-SB-02-EW-0010 | 127.8d | 0d | Electrician [78 h]; LC Crew [52 h] | 2,906.05 | 1.3.8.20 | CONS | CONS | ZONE-3 | REALM | Snack-2 |
|  | 4 | **Mechanical Works** |  |  | 2017-03-14 | 2017-07-27 |  |  |  |  |  |  |  |  |  |  |  |
| CON-Z3-SB-02-ME-0010 |  | Installation of Water Supply System (Pipes,Fittings and Accessories) |  | 16d | 2017-03-14 | 2017-04-02 | CON-Z3-SB-02-CW-0030 | 211.8d | 0d | Plumber [52 h]; Common Labor / Helper [52 h] | 4,843.41 | 1.3.8.20 | CONS | CONS | ZONE-3 | REALM | Snack-2 |
| CON-Z3-SB-02-ME-0020 |  | Installation of Sewer System |  | 16d | 2017-04-02 | 2017-04-20 | CON-Z3-SB-02-ME-0010 | 211.8d | 0d | Plumber [52 h]; Common Labor / Helper [52 h] | 4,843.41 | 1.3.8.20 | CONS | CONS | ZONE-3 | REALM | Snack-2 |
| CON-Z3-SB-02-ME-0040 |  | Installation of Tie-in Connection for Water Supply |  | 4d | 2017-04-02 | 2017-04-06 | CON-Z3-SB-02-ME-0010 | 231.8d | 20d | Plumber [52 h]; Common Labor / Helper [52 h] | 807.24 | 1.3.8.20 | CONS | CONS | ZONE-3 | REALM | Snack-2 |
| CON-Z3-SB-02-ME-0030 |  | Instalaltion of Floor Drain and Cleanout |  | 4d | 2017-04-20 | 2017-04-25 | CON-Z3-SB-02-ME-0020 | 211.8d | 0d | Plumber [52 h]; Common Labor / Helper [52 h] | 1,614.47 | 1.3.8.20 | CONS | CONS | ZONE-3 | REALM | Snack-2 |
| CON-Z3-SB-02-ME-0050 |  | Installation of Tie-in Connection for Drainage |  | 4d | 2017-04-25 | 2017-04-30 | CON-Z3-SB-02-ME-0030, CON-Z3-SB-02-ME-0020 | 211.8d | 0d | Plumber [52 h]; Common Labor / Helper [52 h] | 807.24 | 1.3.8.20 | CONS | CONS | ZONE-3 | REALM | Snack-2 |
| CON-Z3-SB-02-ME-0060 |  | Installation of Fire Extinguisher (FE-2) |  | 1.6d | 2017-07-23 | 2017-07-24 | CON-Z3-SB-02-EW-0020 SS | 143.8d | 0d | Common Labor / Helper [52 h] | 1,614.47 | 1.3.8.20 | CONS | CONS | ZONE-3 | REALM | Snack-2 |
| CON-Z3-SB-02-ME-0070 |  | Installation of Window AC (1.5 ton) |  | 2.4d | 2017-07-24 | 2017-07-27 | CON-Z3-SB-02-ME-0060, PR-Z3-GE-GE-240-0080 | 143.8d | 0d | Mechanical Technician [26 h]; HVAC Crew [26 h] | 1,614.47 | 1.3.8.20 | CONS | CONS | ZONE-3 | REALM | Snack-2 |
|  | 6 | **Testing & Pre-Commissioning** |  |  | 2017-04-30 | 2017-08-29 |  |  |  |  |  |  |  |  |  |  |  |
| CON-Z3-SB-02-TC-0010 |  | Hydro Testing - Plumbing Works |  | 12d | 2017-04-30 | 2017-05-14 | CON-Z3-SB-02-ME-0050, CON-Z3-SB-02-ME-0010, CON-Z3-SB-02-ME-0040, CON-Z3-SB-02-ME-0020 | 211.8d | 84d | Plumber [26 h]; Common Labor / Helper [52 h]; Driver - Water Tanker [26 h] | 4,843.41 | 1.3.8.20 | CONS | CONS | ZONE-3 | REALM | Snack-2 |
| CON-Z3-SB-02-TC-0020 |  | Testing & Pre-commissioning of Mechanical Works |  | 8d | 2017-07-27 | 2017-08-06 | CON-Z3-SB-02-ME-0070, CON-Z3-SB-02-ME-0060 | 143.8d | 16d | Mechanical Technician [52 h]; Specialist Works Crew [26 h] | 1,937.37 | 1.3.8.20 | CONS | CONS | ZONE-3 | REALM | Snack-2 |
| CON-Z3-SB-02-TC-0030 |  | Testing & Pre-commissioning of Electrical Works |  | 8d | 2017-08-15 | 2017-08-24 | CON-Z3-SB-02-EW-0020, CON-Z3-SB-02-EW-0010 | 127.8d | 0d | Electrician [78 h]; LC Crew [52 h] | 2,906.05 | 1.3.8.20 | CONS | CONS | ZONE-3 | REALM | Snack-2 |
| CON-Z3-SB-02-TC-0040 |  | Completion of Snack Bar # 2 |  | 4d | 2017-08-24 | 2017-08-29 | CON-Z3-SB-02-TC-0010, CON-Z3-SB-02-TC-0020, CON-Z3-SB-02-TC-0030 | 127.8d |  |  |  | 1.3.8.20 | CONS | CONS | ZONE-3 | REALM | Snack-2 |
|  | 2 | **Snack Bar # 03** |  |  | 2017-03-08 | 2017-09-20 |  |  |  |  |  |  |  |  |  |  |  |
|  | 1 | **Civil / Structural Works** |  |  | 2017-03-08 | 2017-04-01 |  |  |  |  |  |  |  |  |  |  |  |
| CON-Z3-SB-03-CW-0010 |  | Start of Snack Bar # 03 | milestone | 0d | 2017-03-08 | 2017-03-08 | CON-Z3-SB-02-CW-0010 SS+15d | 97.8d | 0d |  |  | 1.3.8.20 | CONS | CONS | ZONE-3 | REALM | Snack-3 |
| CON-Z3-SB-03-CW-0020 |  | Backfilling around the building |  | 8d | 2017-03-08 | 2017-03-18 | CON-Z3-SB-03-CW-0010 | 112.8d | 0d | Common Labor / Helper [78 h]; Operator - Loader [26 h]; Driver - Dump Truck [26 h]; Operator - Bobcat [26 h]; Operator - Roller-Compactor (2~10 Ton) [26 h]; Operator - Roller (25 Ton) [26 h]; Driver - Water Tanker [26 h]; Loader [28 h]; Dump Truck [28 h]; Bobcat [28 h]; Roller-Compactor (2~10 Ton) [28 h]; Roller-Compactor (25 Ton) [28 h]; Water Tanker [28 h] | 1,937.37 | 1.3.8.20 | CONS | CONS | ZONE-3 | REALM | Snack-3 |
| CON-Z3-SB-03-CW-0030 |  | Installation of Reinforced Concrete Slab on Garde |  | 12d | 2017-03-18 | 2017-04-01 | CON-Z3-SB-03-CW-0020 | 112.8d | 0d | Steel Fixer [52 h]; Shuttering Carpenter [78 h]; Concrete Mason [78 h]; Common Labor / Helper [78 h] | 1,291.58 | 1.3.8.20 | CONS | CONS | ZONE-3 | REALM | Snack-3 |
|  | 2 | **Architectural Works / Finishes** |  |  | 2017-04-01 | 2017-07-26 |  |  |  |  |  |  |  |  |  |  |  |
| CON-Z3-SB-03-AR-0010 |  | External Plastering |  | 4d | 2017-04-01 | 2017-04-05 | CON-Z3-SB-03-CW-0030 | 112.8d | 0d | Concrete Mason [78 h]; Common Labor / Helper [26 h]; Scaffolder [26 h]; Finishing Work Crew [52 h] | 516.63 | 1.3.8.20 | CONS | CONS | ZONE-3 | REALM | Snack-3 |
| CON-Z3-SB-03-AR-0020 |  | Internal Plastering |  | 4d | 2017-04-05 | 2017-04-10 | CON-Z3-SB-03-AR-0010 | 112.8d | 0d | Concrete Mason [78 h]; Common Labor / Helper [26 h]; Scaffolder [26 h]; Finishing Work Crew [52 h] | 1,808.21 | 1.3.8.20 | CONS | CONS | ZONE-3 | REALM | Snack-3 |
| CON-Z3-SB-03-AR-0030 |  | Installation of Waterproofing System on the sloped roof of bar |  | 8d | 2017-04-10 | 2017-04-19 | CON-Z3-SB-03-AR-0020 | 112.8d | 0d | Common Labor / Helper [52 h]; Water Proofing Crew [52 h]; Finishing Work Crew [52 h] | 1,291.58 | 1.3.8.20 | CONS | CONS | ZONE-3 | REALM | Snack-3 |
| CON-Z3-SB-03-AR-0090 |  | Installation of Moiture resistant gypsum board ceiling |  | 12d | 2017-04-10 | 2017-04-24 | CON-Z3-SB-03-AR-0020 | 156.8d | 44d | Common Labor / Helper [52 h]; Scaffolder [52 h]; Plaster Mason [78 h]; Gypsum Walls & Ceiling Crew [52 h] | 2,583.15 | 1.3.8.20 | CONS | CONS | ZONE-3 | REALM | Snack-3 |
| CON-Z3-SB-03-AR-0040 |  | Installation of Concrete Topping |  | 4d | 2017-04-19 | 2017-04-24 | CON-Z3-SB-03-AR-0030, CON-Z3-SB-03-AR-0020 | 112.8d | 0d | Concrete Mason [78 h] | 1,291.58 | 1.3.8.20 | CONS | CONS | ZONE-3 | REALM | Snack-3 |
| CON-Z3-SB-03-AR-0050 |  | Installation of Ceramic tiles for floors |  | 16d | 2017-04-24 | 2017-05-13 | CON-Z3-SB-03-AR-0040 | 112.8d | 0d | Common Labor / Helper [104 h]; Block Mason [52 h]; Tiling Crew [52 h] | 2,583.15 | 1.3.8.20 | CONS | CONS | ZONE-3 | REALM | Snack-3 |
| CON-Z3-SB-03-AR-0060 |  | Installation of Ceramic Floor walls |  | 12d | 2017-05-13 | 2017-05-27 | CON-Z3-SB-03-AR-0050 | 112.8d | 0d | Block Mason [78 h]; Tiling Crew [52 h] | 2,583.15 | 1.3.8.20 | CONS | CONS | ZONE-3 | REALM | Snack-3 |
| CON-Z3-SB-03-AR-0070 |  | External Painting |  | 8d | 2017-05-27 | 2017-06-05 | CON-Z3-SB-03-AR-0060 | 112.8d | 0d | Common Labor / Helper [26 h]; Scaffolder [52 h]; Painter [78 h] | 1,291.58 | 1.3.8.20 | CONS | CONS | ZONE-3 | REALM | Snack-3 |
| CON-Z3-SB-03-AR-0080 |  | Internal Painting |  | 8d | 2017-06-05 | 2017-06-14 | CON-Z3-SB-03-AR-0070 | 112.8d | 0d | Common Labor / Helper [26 h]; Scaffolder [52 h]; Painter [78 h] | 2,583.15 | 1.3.8.20 | CONS | CONS | ZONE-3 | REALM | Snack-3 |
| CON-Z3-SB-03-AR-0100 |  | Apply Textured paint finish for ceiling |  | 4d | 2017-06-14 | 2017-06-19 | CON-Z3-SB-03-AR-0080, CON-Z3-SB-03-AR-0090 | 112.8d | 0d | Common Labor / Helper [26 h]; Scaffolder [52 h]; Painter [78 h]; Gypsum Walls & Ceiling Crew [52 h] | 1,291.58 | 1.3.8.20 | CONS | CONS | ZONE-3 | REALM | Snack-3 |
| CON-Z3-SB-03-AR-0120 |  | Installation of Doors and Windows |  | 8d | 2017-06-19 | 2017-07-03 | CON-Z3-SB-03-AR-0100 | 112.8d | 0d | Shuttering Carpenter [52 h]; Common Labor / Helper [26 h] | 2,583.15 | 1.3.8.20 | CONS | CONS | ZONE-3 | REALM | Snack-3 |
| CON-Z3-SB-03-AR-0130 |  | Installation of Composit Wood Trellis |  | 12d | 2017-07-03 | 2017-07-17 | CON-Z3-SB-03-AR-0120 | 112.8d | 0d | Scaffolder [52 h]; Wood Works Crew [52 h]; Shuttering Carpenter [52 h]; Common Labor / Helper [78 h] | 3,874.73 | 1.3.8.20 | CONS | CONS | ZONE-3 | REALM | Snack-3 |
| CON-Z3-SB-03-AR-0140 |  | Installation of Telephonic Cabinet |  | 4d | 2017-07-17 | 2017-07-22 | CON-Z3-SB-03-AR-0130 | 112.8d | 0d | Common Labor / Helper [52 h]; Wood Works Crew [52 h] | 774.95 | 1.3.8.20 | CONS | CONS | ZONE-3 | REALM | Snack-3 |
| CON-Z3-SB-03-AR-0150 |  | Installation of Laminated Wall Cabinet |  | 4d | 2017-07-22 | 2017-07-26 | CON-Z3-SB-03-AR-0140 | 112.8d | 0d | Common Labor / Helper [52 h]; Wood Works Crew [52 h] | 774.95 | 1.3.8.20 | CONS | CONS | ZONE-3 | REALM | Snack-3 |

Notes:
- CON-Z3-SB-02-EW-0010: Expenses: (New Expense Item) 6780.78
- CON-Z3-SB-02-EW-0020: Expenses: (New Expense Item) 2906.05
- CON-Z3-SB-02-ME-0010: Expenses: (New Expense Item) 4843.41
- CON-Z3-SB-02-ME-0020: Expenses: (New Expense Item) 4843.41
- CON-Z3-SB-02-ME-0040: Expenses: (New Expense Item) 807.24
- CON-Z3-SB-02-ME-0030: Expenses: (New Expense Item) 1614.47
- CON-Z3-SB-02-ME-0050: Expenses: (New Expense Item) 807.24
- CON-Z3-SB-02-ME-0060: Expenses: (New Expense Item) 1614.47
- CON-Z3-SB-02-ME-0070: Expenses: (New Expense Item) 1614.47
- CON-Z3-SB-02-TC-0010: Expenses: (New Expense Item) 4843.41
- CON-Z3-SB-02-TC-0020: Expenses: (New Expense Item) 1937.37
- CON-Z3-SB-02-TC-0030: Expenses: (New Expense Item) 2906.05
- CON-Z3-SB-03-CW-0020: Expenses: (New Expense Item) 1937.37
- CON-Z3-SB-03-CW-0030: Expenses: (New Expense Item) 1291.58
- CON-Z3-SB-03-AR-0010: Expenses: (New Expense Item) 516.63
- CON-Z3-SB-03-AR-0020: Expenses: (New Expense Item) 1808.21
- CON-Z3-SB-03-AR-0030: Expenses: (New Expense Item) 1291.58
- CON-Z3-SB-03-AR-0090: Expenses: (New Expense Item) 2583.15
- CON-Z3-SB-03-AR-0040: Expenses: (New Expense Item) 1291.58
- CON-Z3-SB-03-AR-0050: Expenses: (New Expense Item) 2583.15
- CON-Z3-SB-03-AR-0060: Expenses: (New Expense Item) 2583.15
- CON-Z3-SB-03-AR-0070: Expenses: (New Expense Item) 1291.58
- CON-Z3-SB-03-AR-0080: Expenses: (New Expense Item) 2583.15
- CON-Z3-SB-03-AR-0100: Expenses: (New Expense Item) 1291.58
- CON-Z3-SB-03-AR-0120: Expenses: (New Expense Item) 2583.15
- CON-Z3-SB-03-AR-0130: Expenses: (New Expense Item) 3874.73
- CON-Z3-SB-03-AR-0140: Expenses: (New Expense Item) 774.95
- CON-Z3-SB-03-AR-0150: Expenses: (New Expense Item) 774.95

| ID | WBS | Activity | Type | Duration | Start | Finish | Predecessors | Total float | Free float | Resources | Cost | RPI_P2 - BOQ ITEMS | RPI_P2 - CONSTRUCTION | RPI_P2 - PHASE | RPI_P2 - ZONES | RPI_P2 - AREAS | RPI_P2 - BUILDINGS |
| --- | --- | --- | --- | --- | --- | --- | --- | --- | --- | --- | --- | --- | --- | --- | --- | --- | --- |
|  | 3 | **Electrical Works** |  |  | 2017-07-26 | 2017-09-06 |  |  |  |  |  |  |  |  |  |  |  |
| CON-Z3-SB-03-EW-0010 |  | Instalaltion of Eelectric Wiring Devices,Cables and Accessories |  | 12d | 2017-07-26 | 2017-08-09 | CON-Z3-SB-03-AR-0150 | 112.8d | 0d | Electrician [78 h]; LC Crew [52 h] | 6,780.78 | 1.3.8.20 | CONS | CONS | ZONE-3 | REALM | Snack-3 |
| CON-Z3-SB-03-EW-0020 |  | Installation of Internal and External Lighting Fixures and Accessories |  | 20d | 2017-08-09 | 2017-09-06 | CON-Z3-SB-03-EW-0010 | 112.8d | 0d | Electrician [78 h]; LC Crew [52 h] | 2,906.05 | 1.3.8.20 | CONS | CONS | ZONE-3 | REALM | Snack-3 |
|  | 4 | **Mechanical Works** |  |  | 2017-04-01 | 2017-08-14 |  |  |  |  |  |  |  |  |  |  |  |
| CON-Z3-SB-03-ME-0010 |  | Installation of Water Supply System (Pipes,Fittings and Accessories) |  | 16d | 2017-04-01 | 2017-04-19 | CON-Z3-SB-03-CW-0030 | 196.8d | 0d | Plumber [52 h]; Common Labor / Helper [52 h] | 4,843.41 | 1.3.8.20 | CONS | CONS | ZONE-3 | REALM | Snack-3 |
| CON-Z3-SB-03-ME-0020 |  | Installation of Sewer System |  | 16d | 2017-04-19 | 2017-05-08 | CON-Z3-SB-03-ME-0010 | 196.8d | 0d | Plumber [52 h]; Common Labor / Helper [52 h] | 4,843.41 | 1.3.8.20 | CONS | CONS | ZONE-3 | REALM | Snack-3 |
| CON-Z3-SB-03-ME-0040 |  | Installation of Tie-in Connection for Water Supply |  | 4d | 2017-04-19 | 2017-04-24 | CON-Z3-SB-03-ME-0010 | 216.8d | 20d | Plumber [52 h]; Common Labor / Helper [52 h] | 807.24 | 1.3.8.20 | CONS | CONS | ZONE-3 | REALM | Snack-3 |
| CON-Z3-SB-03-ME-0030 |  | Instalaltion of Floor Drain and Cleanout |  | 4d | 2017-05-08 | 2017-05-13 | CON-Z3-SB-03-ME-0020 | 196.8d | 0d | Plumber [52 h]; Common Labor / Helper [52 h] | 1,614.47 | 1.3.8.20 | CONS | CONS | ZONE-3 | REALM | Snack-3 |
| CON-Z3-SB-03-ME-0050 |  | Installation of Tie-in Connection for Drainage |  | 4d | 2017-05-13 | 2017-05-17 | CON-Z3-SB-03-ME-0020, CON-Z3-SB-03-ME-0030 | 196.8d | 0d | Plumber [52 h]; Common Labor / Helper [52 h] | 807.24 | 1.3.8.20 | CONS | CONS | ZONE-3 | REALM | Snack-3 |
| CON-Z3-SB-03-ME-0060 |  | Installation of Fire Extinguisher (FE-2) |  | 1.6d | 2017-08-09 | 2017-08-10 | CON-Z3-SB-03-EW-0020 SS | 128.8d | 0d | Common Labor / Helper [52 h] | 1,614.47 | 1.3.8.20 | CONS | CONS | ZONE-3 | REALM | Snack-3 |
| CON-Z3-SB-03-ME-0070 |  | Installation of Window AC (1.5 ton) |  | 2.4d | 2017-08-10 | 2017-08-14 | CON-Z3-SB-03-ME-0060 | 128.8d | 0d | Mechanical Technician [26 h]; HVAC Crew [26 h] | 1,614.47 | 1.3.8.20 | CONS | CONS | ZONE-3 | REALM | Snack-3 |
|  | 6 | **Testing & Pre-Commissioning** |  |  | 2017-05-17 | 2017-09-20 |  |  |  |  |  |  |  |  |  |  |  |
| CON-Z3-SB-03-TC-0020 |  | Hydro Testing - Plumbing Works |  | 12d | 2017-05-17 | 2017-05-31 | CON-Z3-SB-03-ME-0010, CON-Z3-SB-03-ME-0020, CON-Z3-SB-03-ME-0050, CON-Z3-SB-03-ME-0040 | 196.8d | 84d | Plumber [26 h]; Common Labor / Helper [52 h]; Driver - Water Tanker [26 h] | 1,937.37 | 1.3.8.20 | CONS | CONS | ZONE-3 | REALM | Snack-3 |
| CON-Z3-SB-03-TC-0030 |  | Testing & Pre-commissioning of Mechanical Works |  | 8d | 2017-08-14 | 2017-08-23 | CON-Z3-SB-03-ME-0060, CON-Z3-SB-03-ME-0070 | 128.8d | 16d | Mechanical Technician [52 h]; Specialist Works Crew [26 h] | 2,906.05 | 1.3.8.20 | CONS | CONS | ZONE-3 | REALM | Snack-3 |
| CON-Z3-SB-03-TC-0010 |  | Testing & Pre-commissioning of Electrical Works |  | 8d | 2017-09-06 | 2017-09-16 | CON-Z3-SB-03-EW-0020, CON-Z3-SB-03-EW-0010 | 112.8d | 0d | Electrician [78 h]; LC Crew [52 h] | 4,843.41 | 1.3.8.20 | CONS | CONS | ZONE-3 | REALM | Snack-3 |
| CON-Z3-SB-03-TC-0040 |  | Completion of Snack Bar # 3 |  | 4d | 2017-09-16 | 2017-09-20 | CON-Z3-SB-03-TC-0010, CON-Z3-SB-03-TC-0030, CON-Z3-SB-03-TC-0020 | 112.8d |  |  |  | 1.3.8.20 | CONS | CONS | ZONE-3 | REALM | Snack-3 |
|  | 3 | **Snack Bar # 04** |  |  | 2017-03-26 | 2017-10-09 |  |  |  |  |  |  |  |  |  |  |  |
|  | 1 | **Civil / Structural Works** |  |  | 2017-03-26 | 2017-04-18 |  |  |  |  |  |  |  |  |  |  |  |
| CON-Z3-SB-04-CW-0010 |  | Start of Snack Bar # 04 | milestone | 0d | 2017-03-26 | 2017-03-26 | CON-Z3-SB-03-CW-0010 SS+15d | 97.8d | 0d |  |  | 1.3.8.20 | CONS | CONS | ZONE-3 | REALM | Snack-4 |
| CON-Z3-SB-04-CW-0020 |  | Backfilling around the building |  | 8d | 2017-03-26 | 2017-04-04 | CON-Z3-SB-04-CW-0010 | 97.8d | 0d | Common Labor / Helper [78 h]; Operator - Loader [26 h]; Driver - Dump Truck [26 h]; Operator - Bobcat [26 h]; Operator - Roller-Compactor (2~10 Ton) [26 h]; Operator - Roller (25 Ton) [26 h]; Driver - Water Tanker [26 h]; Loader [28 h]; Dump Truck [28 h]; Bobcat [28 h]; Roller-Compactor (2~10 Ton) [28 h]; Roller-Compactor (25 Ton) [28 h]; Water Tanker [28 h] | 1,937.37 | 1.3.8.20 | CONS | CONS | ZONE-3 | REALM | Snack-4 |
| CON-Z3-SB-04-CW-0030 |  | Installation of Reinforced Concrete Slab on Garde |  | 12d | 2017-04-04 | 2017-04-18 | CON-Z3-SB-04-CW-0020 | 97.8d | 0d | Steel Fixer [52 h]; Shuttering Carpenter [78 h]; Concrete Mason [78 h]; Common Labor / Helper [78 h] | 1,291.58 | 1.3.8.20 | CONS | CONS | ZONE-3 | REALM | Snack-4 |
|  | 2 | **Architectural Works / Finishes** |  |  | 2017-04-18 | 2017-08-13 |  |  |  |  |  |  |  |  |  |  |  |
| CON-Z3-SB-04-AR-0010 |  | External Plastering |  | 4d | 2017-04-18 | 2017-04-23 | CON-Z3-SB-04-CW-0030 | 97.8d | 0d | Concrete Mason [78 h]; Common Labor / Helper [26 h]; Scaffolder [26 h]; Finishing Work Crew [52 h] | 516.63 | 1.3.8.20 | CONS | CONS | ZONE-3 | REALM | Snack-4 |
| CON-Z3-SB-04-AR-0020 |  | Internal Plastering |  | 4d | 2017-04-23 | 2017-04-27 | CON-Z3-SB-04-AR-0010 | 97.8d | 0d | Concrete Mason [78 h]; Common Labor / Helper [26 h]; Scaffolder [26 h]; Finishing Work Crew [52 h] | 1,808.21 | 1.3.8.20 | CONS | CONS | ZONE-3 | REALM | Snack-4 |
| CON-Z3-SB-04-AR-0030 |  | Installation of Waterproofing System on the sloped roof of bar |  | 8d | 2017-04-27 | 2017-05-07 | CON-Z3-SB-04-AR-0020 | 97.8d | 0d | Common Labor / Helper [52 h]; Water Proofing Crew [52 h]; Finishing Work Crew [52 h] | 1,291.58 | 1.3.8.20 | CONS | CONS | ZONE-3 | REALM | Snack-4 |
| CON-Z3-SB-04-AR-0090 |  | Installation of Moiture resistant gypsum board ceiling |  | 12d | 2017-04-27 | 2017-05-11 | CON-Z3-SB-04-AR-0020 | 141.8d | 44d | Common Labor / Helper [52 h]; Scaffolder [52 h]; Plaster Mason [78 h]; Gypsum Walls & Ceiling Crew [52 h] | 2,583.15 | 1.3.8.20 | CONS | CONS | ZONE-3 | REALM | Snack-4 |
| CON-Z3-SB-04-AR-0040 |  | Installation of Concrete Topping |  | 4d | 2017-05-07 | 2017-05-11 | CON-Z3-SB-04-AR-0020, CON-Z3-SB-04-AR-0030 | 97.8d | 0d | Concrete Mason [78 h] | 1,291.58 | 1.3.8.20 | CONS | CONS | ZONE-3 | REALM | Snack-4 |
| CON-Z3-SB-04-AR-0050 |  | Installation of Ceramic tiles for floors |  | 16d | 2017-05-11 | 2017-05-30 | CON-Z3-SB-04-AR-0040 | 97.8d | 0d | Common Labor / Helper [104 h]; Block Mason [52 h]; Tiling Crew [52 h] | 2,583.15 | 1.3.8.20 | CONS | CONS | ZONE-3 | REALM | Snack-4 |
| CON-Z3-SB-04-AR-0060 |  | Installation of Ceramic Floor walls |  | 12d | 2017-05-30 | 2017-06-13 | CON-Z3-SB-04-AR-0050 | 97.8d | 0d | Block Mason [78 h]; Tiling Crew [52 h] | 2,583.15 | 1.3.8.20 | CONS | CONS | ZONE-3 | REALM | Snack-4 |
| CON-Z3-SB-04-AR-0070 |  | External Painting |  | 8d | 2017-06-13 | 2017-06-22 | CON-Z3-SB-04-AR-0060 | 97.8d | 0d | Common Labor / Helper [26 h]; Scaffolder [52 h]; Painter [78 h] | 1,291.58 | 1.3.8.20 | CONS | CONS | ZONE-3 | REALM | Snack-4 |
| CON-Z3-SB-04-AR-0080 |  | Internal Painting |  | 8d | 2017-06-22 | 2017-07-06 | CON-Z3-SB-04-AR-0070 | 97.8d | 0d | Common Labor / Helper [26 h]; Scaffolder [52 h]; Painter [78 h] | 2,583.15 | 1.3.8.20 | CONS | CONS | ZONE-3 | REALM | Snack-4 |
| CON-Z3-SB-04-AR-0100 |  | Apply Textured paint finish for ceiling |  | 4d | 2017-07-06 | 2017-07-11 | CON-Z3-SB-04-AR-0080, CON-Z3-SB-04-AR-0090 | 97.8d | 0d | Common Labor / Helper [26 h]; Scaffolder [52 h]; Painter [78 h]; Gypsum Walls & Ceiling Crew [52 h] | 1,291.58 | 1.3.8.20 | CONS | CONS | ZONE-3 | REALM | Snack-4 |
| CON-Z3-SB-04-AR-0110 |  | Installation of Doors and Windows |  | 8d | 2017-07-11 | 2017-07-20 | CON-Z3-SB-04-AR-0100 | 97.8d | 0d | Shuttering Carpenter [52 h]; Common Labor / Helper [26 h] | 2,583.15 | 1.3.8.20 | CONS | CONS | ZONE-3 | REALM | Snack-4 |
| CON-Z3-SB-04-AR-0120 |  | Installation of Composit Wood Trellis |  | 12d | 2017-07-20 | 2017-08-03 | CON-Z3-SB-04-AR-0110 | 97.8d | 0d | Shuttering Carpenter [52 h]; Common Labor / Helper [78 h]; Scaffolder [52 h]; Wood Works Crew [52 h] | 3,874.73 | 1.3.8.20 | CONS | CONS | ZONE-3 | REALM | Snack-4 |
| CON-Z3-SB-04-AR-0130 |  | Installation of Telephonic Cabinet |  | 4d | 2017-08-03 | 2017-08-08 | CON-Z3-SB-04-AR-0120 | 97.8d | 0d | Common Labor / Helper [52 h]; Wood Works Crew [52 h] | 774.95 | 1.3.8.20 | CONS | CONS | ZONE-3 | REALM | Snack-4 |
| CON-Z3-SB-04-AR-0140 |  | Installation of Laminated Wall Cabinet |  | 4d | 2017-08-08 | 2017-08-13 | CON-Z3-SB-04-AR-0130 | 97.8d | 0d | Common Labor / Helper [52 h]; Wood Works Crew [52 h] | 774.95 | 1.3.8.20 | CONS | CONS | ZONE-3 | REALM | Snack-4 |

Notes:
- CON-Z3-SB-03-EW-0010: Expenses: (New Expense Item) 6780.78
- CON-Z3-SB-03-EW-0020: Expenses: (New Expense Item) 2906.05
- CON-Z3-SB-03-ME-0010: Expenses: (New Expense Item) 4843.41
- CON-Z3-SB-03-ME-0020: Expenses: (New Expense Item) 4843.41
- CON-Z3-SB-03-ME-0040: Expenses: (New Expense Item) 807.24
- CON-Z3-SB-03-ME-0030: Expenses: (New Expense Item) 1614.47
- CON-Z3-SB-03-ME-0050: Expenses: (New Expense Item) 807.24
- CON-Z3-SB-03-ME-0060: Expenses: (New Expense Item) 1614.47
- CON-Z3-SB-03-ME-0070: Expenses: (New Expense Item) 1614.47
- CON-Z3-SB-03-TC-0020: Expenses: (New Expense Item) 1937.37
- CON-Z3-SB-03-TC-0030: Expenses: (New Expense Item) 2906.05
- CON-Z3-SB-03-TC-0010: Expenses: (New Expense Item) 4843.41
- CON-Z3-SB-04-CW-0020: Expenses: (New Expense Item) 1937.37
- CON-Z3-SB-04-CW-0030: Expenses: (New Expense Item) 1291.58
- CON-Z3-SB-04-AR-0010: Expenses: (New Expense Item) 516.63
- CON-Z3-SB-04-AR-0020: Expenses: (New Expense Item) 1808.21
- CON-Z3-SB-04-AR-0030: Expenses: (New Expense Item) 1291.58
- CON-Z3-SB-04-AR-0090: Expenses: (New Expense Item) 2583.15
- CON-Z3-SB-04-AR-0040: Expenses: (New Expense Item) 1291.58
- CON-Z3-SB-04-AR-0050: Expenses: (New Expense Item) 2583.15
- CON-Z3-SB-04-AR-0060: Expenses: (New Expense Item) 2583.15
- CON-Z3-SB-04-AR-0070: Expenses: (New Expense Item) 1291.58
- CON-Z3-SB-04-AR-0080: Expenses: (New Expense Item) 2583.15
- CON-Z3-SB-04-AR-0100: Expenses: (New Expense Item) 1291.58
- CON-Z3-SB-04-AR-0110: Expenses: (New Expense Item) 2583.15
- CON-Z3-SB-04-AR-0120: Expenses: (New Expense Item) 3874.73
- CON-Z3-SB-04-AR-0130: Expenses: (New Expense Item) 774.95
- CON-Z3-SB-04-AR-0140: Expenses: (New Expense Item) 774.95

| ID | WBS | Activity | Type | Duration | Start | Finish | Predecessors | Total float | Free float | Resources | Cost | RPI_P2 - BOQ ITEMS | RPI_P2 - CONSTRUCTION | RPI_P2 - PHASE | RPI_P2 - ZONES | RPI_P2 - AREAS | RPI_P2 - BUILDINGS |
| --- | --- | --- | --- | --- | --- | --- | --- | --- | --- | --- | --- | --- | --- | --- | --- | --- | --- |
|  | 3 | **Electrical Works** |  |  | 2017-08-13 | 2017-09-25 |  |  |  |  |  |  |  |  |  |  |  |
| CON-Z3-SB-04-EW-0010 |  | Instalaltion of Eelectric Wiring Devices,Cables and Accessories |  | 12d | 2017-08-13 | 2017-08-27 | CON-Z3-SB-04-AR-0140 | 97.8d | 0d | Electrician [78 h]; LC Crew [52 h] | 6,780.78 | 1.3.8.20 | CONS | CONS | ZONE-3 | REALM | Snack-4 |
| CON-Z3-SB-04-EW-0020 |  | Installation of Internal and External Lighting Fixures and Accessories |  | 20d | 2017-08-27 | 2017-09-25 | CON-Z3-SB-04-EW-0010 | 97.8d | 0d | Electrician [78 h]; LC Crew [52 h] | 2,906.05 | 1.3.8.20 | CONS | CONS | ZONE-3 | REALM | Snack-4 |
|  | 4 | **Mechanical Works** |  |  | 2017-04-18 | 2017-09-05 |  |  |  |  |  |  |  |  |  |  |  |
| CON-Z3-SB-04-ME-0010 |  | Installation of Water Supply System (Pipes,Fittings and Accessories) |  | 16d | 2017-04-18 | 2017-05-07 | CON-Z3-SB-04-CW-0030 | 181.8d | 0d | Plumber [52 h]; Common Labor / Helper [52 h] | 4,843.41 | 1.3.8.20 | CONS | CONS | ZONE-3 | REALM | Snack-4 |
| CON-Z3-SB-04-ME-0020 |  | Installation of Sewer System |  | 16d | 2017-05-07 | 2017-05-25 | CON-Z3-SB-04-ME-0010 | 181.8d | 0d | Plumber [52 h]; Common Labor / Helper [52 h] | 4,843.41 | 1.3.8.20 | CONS | CONS | ZONE-3 | REALM | Snack-4 |
| CON-Z3-SB-04-ME-0040 |  | Installation of Tie-in Connection for Water Supply |  | 4d | 2017-05-07 | 2017-05-11 | CON-Z3-SB-04-ME-0010 | 201.8d | 20d | Plumber [52 h]; Common Labor / Helper [52 h] | 807.24 | 1.3.8.20 | CONS | CONS | ZONE-3 | REALM | Snack-4 |
| CON-Z3-SB-04-ME-0030 |  | Instalaltion of Floor Drain and Cleanout |  | 4d | 2017-05-25 | 2017-05-30 | CON-Z3-SB-04-ME-0020 | 181.8d | 0d | Plumber [52 h]; Common Labor / Helper [52 h] | 1,614.47 | 1.3.8.20 | CONS | CONS | ZONE-3 | REALM | Snack-4 |
| CON-Z3-SB-04-ME-0050 |  | Installation of Tie-in Connection for Drainage |  | 4d | 2017-05-30 | 2017-06-04 | CON-Z3-SB-04-ME-0030, CON-Z3-SB-04-ME-0020 | 181.8d | 0d | Plumber [52 h]; Common Labor / Helper [52 h] | 807.24 | 1.3.8.20 | CONS | CONS | ZONE-3 | REALM | Snack-4 |
| CON-Z3-SB-04-ME-0060 |  | Installation of Fire Extinguisher (FE-2) |  | 1.6d | 2017-08-27 | 2017-08-28 | CON-Z3-SB-04-EW-0020 SS | 113.8d | 0d | Common Labor / Helper [52 h] | 1,614.47 | 1.3.8.20 | CONS | CONS | ZONE-3 | REALM | Snack-4 |
| CON-Z3-SB-04-ME-0070 |  | Installation of Window AC (1.5 ton) |  | 2.4d | 2017-08-28 | 2017-09-05 | CON-Z3-SB-04-ME-0060 | 113.8d | 0d | Mechanical Technician [26 h]; HVAC Crew [26 h] | 1,614.47 | 1.3.8.20 | CONS | CONS | ZONE-3 | REALM | Snack-4 |
|  | 6 | **Testing & Pre-Commissioning** |  |  | 2017-06-04 | 2017-10-09 |  |  |  |  |  |  |  |  |  |  |  |
| CON-Z3-SB-04-TC-0010 |  | Hydro Testing - Plumbing Works |  | 12d | 2017-06-04 | 2017-06-18 | CON-Z3-SB-04-ME-0040, CON-Z3-SB-04-ME-0010, CON-Z3-SB-04-ME-0020, CON-Z3-SB-04-ME-0050 | 181.8d | 84d | Plumber [26 h]; Common Labor / Helper [52 h]; Driver - Water Tanker [26 h] | 4,843.41 | 1.3.8.20 | CONS | CONS | ZONE-3 | REALM | Snack-4 |
| CON-Z3-SB-04-TC-0020 |  | Testing & Pre-commissioning of Mechanical Works |  | 8d | 2017-09-05 | 2017-09-14 | CON-Z3-SB-04-ME-0070, CON-Z3-SB-04-ME-0060 | 113.8d | 16d | Mechanical Technician [52 h]; Specialist Works Crew [26 h] | 1,937.37 | 1.3.8.20 | CONS | CONS | ZONE-3 | REALM | Snack-4 |
| CON-Z3-SB-04-TC-0030 |  | Testing & Pre-commissioning of Electrical Works |  | 8d | 2017-09-25 | 2017-10-04 | CON-Z3-SB-04-EW-0020, CON-Z3-SB-04-EW-0010 | 97.8d | 0d | Electrician [78 h]; LC Crew [52 h] | 2,906.05 | 1.3.8.20 | CONS | CONS | ZONE-3 | REALM | Snack-4 |
| CON-Z3-SB-04-TC-0040 |  | Completion of Snack Bar # 4 |  | 4d | 2017-10-04 | 2017-10-09 | CON-Z3-SB-04-TC-0030, CON-Z3-SB-04-TC-0020, CON-Z3-SB-04-TC-0010 | 97.8d |  |  |  | 1.3.8.20 | CONS | CONS | ZONE-3 | REALM | Snack-4 |
|  | 3 | **Pinic Shelters (30 No.s)** |  |  | 2017-04-04 | 2017-10-28 |  |  |  |  |  |  |  |  |  |  |  |
|  | 1 | **Pinic Shelters - Area - 1 (PS-01 to PS-06)** |  |  | 2017-04-04 | 2017-09-19 |  |  |  |  |  |  |  |  |  |  |  |
|  | 1 | **Civil / Structural Works** |  |  | 2017-04-04 | 2017-05-15 |  |  |  |  |  |  |  |  |  |  |  |
| CON-Z3-PS-01-CW-0010 |  | Start of Pinic Shelters - Area - 1 (PS-01 to PS-06) | milestone | 0d | 2017-04-04 | 2017-04-04 | CON-CON-CON-CON-0010 FS+200d | 4.8d | 0d |  |  | 1.3.8.30 | CONS | CONS | ZONE-3 | REALM | Picnic Shelter |
| CON-Z3-PS-01-CW-0020 |  | General Backfilling |  | 15d | 2017-04-04 | 2017-04-22 | CON-Z3-PS-01-CW-0010 | 36.8d | 0d | Common Labor / Helper [78 h]; Operator - Loader [26 h]; Driver - Dump Truck [26 h]; Operator - Bobcat [26 h]; Operator - Roller-Compactor (2~10 Ton) [26 h]; Operator - Roller (25 Ton) [26 h]; Driver - Water Tanker [26 h]; Loader [28 h]; Dump Truck [28 h]; Bobcat [28 h]; Roller-Compactor (2~10 Ton) [28 h]; Roller-Compactor (25 Ton) [28 h]; Water Tanker [28 h] | 4,640.25 | 1.3.8.30 | CONS | CONS | ZONE-3 | REALM | Picnic Shelter |
| CON-Z3-PS-01-CW-0030 |  | Installation of Reinforced Slab on Grade |  | 20d | 2017-04-22 | 2017-05-15 | CON-Z3-PS-01-CW-0020 | 36.8d | 0d | Steel Fixer [52 h]; Shuttering Carpenter [78 h]; Concrete Mason [78 h]; Common Labor / Helper [78 h] | 6,960.37 | 1.3.8.30 | CONS | CONS | ZONE-3 | REALM | Picnic Shelter |
|  | 2 | **Architectural Works & Finishes** |  |  | 2017-04-26 | 2017-07-27 |  |  |  |  |  |  |  |  |  |  |  |
| CON-Z3-PS-01-AR-0010 |  | Plastering Work |  | 20d | 2017-04-26 | 2017-05-20 | CON-Z3-PS-01-CW-0030 SS+4d | 36.8d | 0d | Concrete Mason [78 h]; Common Labor / Helper [26 h]; Scaffolder [26 h]; Finishing Work Crew [52 h] | 9,280.49 | 1.3.8.30 | CONS | CONS | ZONE-3 | REALM | Picnic Shelter |
| CON-Z3-PS-01-AR-0020 |  | Installation of Composite wood roof trellis and other wood works |  | 15d | 2017-05-20 | 2017-06-06 | CON-Z3-PS-01-AR-0010 | 47.8d | 0d | Shuttering Carpenter [52 h]; Common Labor / Helper [78 h]; Scaffolder [52 h]; Wood Works Crew [52 h] | 18,560.98 | 1.3.8.30 | CONS | CONS | ZONE-3 | REALM | Picnic Shelter |
| CON-Z3-PS-01-AR-0030 |  | Installation of broom finish for the floor area |  | 10d | 2017-06-06 | 2017-06-18 | CON-Z3-PS-01-AR-0020 | 47.8d | 0d | Common Labor / Helper [52 h]; Finishing Work Crew [52 h] | 4,640.25 | 1.3.8.30 | CONS | CONS | ZONE-3 | REALM | Picnic Shelter |
| CON-Z3-PS-01-AR-0040 |  | Painting Work |  | 30d | 2017-06-18 | 2017-07-27 | CON-Z3-PS-01-ME-0010 FF+3d, CON-Z3-PS-01-AR-0030, CON-Z3-PS-01-AR-0010 | 47.8d | 0d | Common Labor / Helper [26 h]; Scaffolder [52 h]; Painter [78 h] | 13,920.74 | 1.3.8.30 | CONS | CONS | ZONE-3 | REALM | Picnic Shelter |

Notes:
- CON-Z3-SB-04-EW-0010: Expenses: (New Expense Item) 6780.78
- CON-Z3-SB-04-EW-0020: Expenses: (New Expense Item) 2906.05
- CON-Z3-SB-04-ME-0010: Expenses: (New Expense Item) 4843.41
- CON-Z3-SB-04-ME-0020: Expenses: (New Expense Item) 4843.41
- CON-Z3-SB-04-ME-0040: Expenses: (New Expense Item) 807.24
- CON-Z3-SB-04-ME-0030: Expenses: (New Expense Item) 1614.47
- CON-Z3-SB-04-ME-0050: Expenses: (New Expense Item) 807.24
- CON-Z3-SB-04-ME-0060: Expenses: (New Expense Item) 1614.47
- CON-Z3-SB-04-ME-0070: Expenses: (New Expense Item) 1614.47
- CON-Z3-SB-04-TC-0010: Expenses: (New Expense Item) 4843.41
- CON-Z3-SB-04-TC-0020: Expenses: (New Expense Item) 1937.37
- CON-Z3-SB-04-TC-0030: Expenses: (New Expense Item) 2906.05
- CON-Z3-PS-01-CW-0020: Expenses: (New Expense Item) 4640.25
- CON-Z3-PS-01-CW-0030: Expenses: (New Expense Item) 6960.37
- CON-Z3-PS-01-AR-0010: Expenses: (New Expense Item) 9280.49
- CON-Z3-PS-01-AR-0020: Expenses: (New Expense Item) 18561
- CON-Z3-PS-01-AR-0030: Expenses: (New Expense Item) 4640.25
- CON-Z3-PS-01-AR-0040: Expenses: (New Expense Item) 13920.7

| ID | WBS | Activity | Type | Duration | Start | Finish | Predecessors | Total float | Free float | Resources | Cost | RPI_P2 - BOQ ITEMS | RPI_P2 - CONSTRUCTION | RPI_P2 - PHASE | RPI_P2 - ZONES | RPI_P2 - AREAS | RPI_P2 - BUILDINGS |
| --- | --- | --- | --- | --- | --- | --- | --- | --- | --- | --- | --- | --- | --- | --- | --- | --- | --- |
|  | 3 | **Mechanical Works** |  |  | 2017-05-20 | 2017-08-19 |  |  |  |  |  |  |  |  |  |  |  |
| CON-Z3-PS-01-ME-0010 |  | Installation of Potable Water Supply System |  | 25d | 2017-05-20 | 2017-06-18 | CON-Z3-PS-01-AR-0010 | 36.8d | 0d | Plumber [78 h]; Common Labor / Helper [52 h] | 40,602.15 | 1.3.8.30 | CONS | CONS | ZONE-3 | REALM | Picnic Shelter |
| CON-Z3-PS-01-ME-0020 |  | Installation of Waste and Vent Pipes |  | 15d | 2017-06-18 | 2017-07-10 | CON-Z3-PS-01-AR-0040 SS, CON-Z3-PS-01-ME-0010 | 47.8d | 0d | Plumber [52 h]; Common Labor / Helper [52 h] | 12,180.64 | 1.3.8.30 | CONS | CONS | ZONE-3 | REALM | Picnic Shelter |
| CON-Z3-PS-01-ME-0030 |  | Installation of Free Standing Sink with drain |  | 10d | 2017-07-10 | 2017-07-22 | CON-Z3-PS-01-ME-0020 | 47.8d | 0d | Plumber [26 h]; Common Labor / Helper [52 h] | 12,180.64 | 1.3.8.30 | CONS | CONS | ZONE-3 | REALM | Picnic Shelter |
| CON-Z3-PS-01-ME-0040 |  | Instalaltion of Tie in Connection for Water Supply system |  | 12d | 2017-07-22 | 2017-08-05 | CON-Z3-PS-01-ME-0030 | 47.8d | 0d | Plumber [52 h]; Common Labor / Helper [52 h] | 8,120.43 | 1.3.8.30 | CONS | CONS | ZONE-3 | REALM | Picnic Shelter |
| CON-Z3-PS-01-ME-0050 |  | Installation of Tie in Connection for Drainage |  | 12d | 2017-08-05 | 2017-08-19 | CON-Z3-PS-01-ME-0040 | 47.8d | 0d | Plumber [52 h]; Common Labor / Helper [52 h] | 8,120.43 | 1.3.8.30 | CONS | CONS | ZONE-3 | REALM | Picnic Shelter |
|  | 4 | **Electrical Works** |  |  | 2017-06-18 | 2017-08-27 |  |  |  |  |  |  |  |  |  |  |  |
| CON-Z3-PS-01-EW-0010 |  | Instalaltion of Conduits |  | 10d | 2017-06-18 | 2017-07-04 | CON-Z3-PS-01-ME-0010 | 36.8d | 0d | Electrician [78 h]; LC Crew [52 h] | 5,800.31 | 1.3.8.30 | CONS | CONS | ZONE-3 | REALM | Picnic Shelter |
| CON-Z3-PS-01-EW-0020 |  | Installation of Cables |  | 10d | 2017-07-04 | 2017-07-16 | CON-Z3-PS-01-EW-0010 | 36.8d | 0d | Electrician [78 h]; LC Crew [52 h] | 8,700.46 | 1.3.8.30 | CONS | CONS | ZONE-3 | REALM | Picnic Shelter |
| CON-Z3-PS-01-EW-0030 |  | Installation of Junction Boxes |  | 8d | 2017-07-16 | 2017-07-25 | CON-Z3-PS-01-EW-0020 | 36.8d | 0d | Electrician [78 h]; LC Crew [52 h] | 5,800.31 | 1.3.8.30 | CONS | CONS | ZONE-3 | REALM | Picnic Shelter |
| CON-Z3-PS-01-EW-0040 |  | Installation of receptacle outlets and wiring devices |  | 12d | 2017-07-25 | 2017-08-08 | CON-Z3-PS-01-EW-0030, PR-Z3-EW-ME-61-0080 | 36.8d | 0d | Electrician [78 h]; LC Crew [52 h] | 23,201.23 | 1.3.8.30 | CONS | CONS | ZONE-3 | REALM | Picnic Shelter |
| CON-Z3-PS-01-EW-0050 |  | Installation of Internal and External Lighting Fixures |  | 16d | 2017-08-08 | 2017-08-27 | CON-Z3-PS-01-EW-0040 | 36.8d | 0d | Electrician [78 h]; LC Crew [52 h] | 14,500.77 | 1.3.8.30 | CONS | CONS | ZONE-3 | REALM | Picnic Shelter |
|  | 6 | **Testing and Precommissioning** |  |  | 2017-08-19 | 2017-09-19 |  |  |  |  |  |  |  |  |  |  |  |
| CON-Z3-PS-01-TC-0010 |  | Testing and Precommissioning of Plumbing Work |  | 12d | 2017-08-19 | 2017-09-06 | CON-Z3-PS-01-ME-0040, CON-Z3-PS-01-ME-0040 FF, CON-Z3-PS-01-ME-0010, CON-Z3-PS-01-ME-0050 | 47.8d | 7d | Plumber [78 h]; Common Labor / Helper [52 h] | 24,361.29 | 1.3.8.30 | CONS | CONS | ZONE-3 | REALM | Picnic Shelter |
| CON-Z3-PS-01-TC-0020 |  | Testing and Precommissioning of Electrical Work |  | 16d | 2017-08-27 | 2017-09-19 | CON-Z3-PS-01-EW-0050 | 36.8d | 0d | Electrician [78 h]; Common Labor / Helper [26 h] | 10,440.55 | 1.3.8.30 | CONS | CONS | ZONE-3 | REALM | Picnic Shelter |
| CON-Z3-PS-01-TC-0030 |  | Finish of Pinic Shelters - Area - 1 (PS-01 to PS-06) | milestone | 0d | 2017-09-14 | 2017-09-14 | CON-Z3-PS-01-TC-0020, CON-Z3-PS-01-TC-0010 | 40.8d | 40.6d | Common Labor / Helper [52 h]; Finishing Work Crew [52 h] |  | 1.3.8.30 | CONS | CONS | ZONE-3 | REALM | Picnic Shelter |
|  | 6 | **Pinic Shelters - Area - 2 (PS-07 to PS-12)** |  |  | 2017-04-16 | 2017-10-21 |  |  |  |  |  |  |  |  |  |  |  |
|  | 1 | **Civil / Structural Works** |  |  | 2017-04-16 | 2017-05-27 |  |  |  |  |  |  |  |  |  |  |  |
| CON-Z3-PS-02-CW-0010 |  | Start of Pinic Shelters - Area - 2 (PS-07 to PS-12) | milestone | 0d | 2017-04-16 | 2017-04-16 | CON-Z3-PS-01-CW-0010 FS+10d | 4.8d | 0d |  |  | 1.3.8.30 | CONS | CONS | ZONE-3 | REALM | Picnic Shelter |
| CON-Z3-PS-02-CW-0020 |  | General Backfilling |  | 15d | 2017-04-16 | 2017-05-03 | CON-Z3-PS-02-CW-0010 | 10.8d | 0d | Common Labor / Helper [78 h]; Operator - Loader [26 h]; Driver - Dump Truck [26 h]; Operator - Bobcat [26 h]; Operator - Roller-Compactor (2~10 Ton) [26 h]; Operator - Roller (25 Ton) [26 h]; Driver - Water Tanker [26 h]; Loader [28 h]; Dump Truck [28 h]; Bobcat [28 h]; Roller-Compactor (2~10 Ton) [28 h]; Roller-Compactor (25 Ton) [28 h]; Water Tanker [28 h] | 4,640.25 | 1.3.8.30 | CONS | CONS | ZONE-3 | REALM | Picnic Shelter |
| CON-Z3-PS-02-CW-0030 |  | Installation of Reinforced Slab on Grade |  | 20d | 2017-05-03 | 2017-05-27 | CON-Z3-PS-02-CW-0020 | 10.8d | 0d | Steel Fixer [52 h]; Shuttering Carpenter [78 h]; Concrete Mason [78 h]; Common Labor / Helper [78 h] | 6,960.37 | 1.3.8.30 | CONS | CONS | ZONE-3 | REALM | Picnic Shelter |
|  | 2 | **Architectural Works & Finishes** |  |  | 2017-05-27 | 2017-08-27 |  |  |  |  |  |  |  |  |  |  |  |
| CON-Z3-PS-02-AR-0010 |  | Plastering Work |  | 20d | 2017-05-27 | 2017-06-19 | CON-Z3-PS-02-CW-0030 | 10.8d | 0d | Concrete Mason [78 h]; Common Labor / Helper [26 h]; Scaffolder [26 h]; Finishing Work Crew [52 h] | 9,280.49 | 1.3.8.30 | CONS | CONS | ZONE-3 | REALM | Picnic Shelter |
| CON-Z3-PS-02-AR-0020 |  | Installation of Composite wood roof trellis and other wood works |  | 15d | 2017-06-19 | 2017-07-11 | CON-Z3-PS-02-AR-0010 | 21.8d | 0d | Shuttering Carpenter [52 h]; Common Labor / Helper [78 h]; Scaffolder [52 h]; Wood Works Crew [52 h] | 18,560.98 | 1.3.8.30 | CONS | CONS | ZONE-3 | REALM | Picnic Shelter |
| CON-Z3-PS-02-AR-0030 |  | Installation of broom finish for the floor area |  | 10d | 2017-07-11 | 2017-07-23 | CON-Z3-PS-02-AR-0020 | 21.8d | 0d | Common Labor / Helper [52 h]; Finishing Work Crew [52 h] | 4,640.25 | 1.3.8.30 | CONS | CONS | ZONE-3 | REALM | Picnic Shelter |
| CON-Z3-PS-02-AR-0040 |  | Painting Work |  | 30d | 2017-07-23 | 2017-08-27 | CON-Z3-PS-02-AR-0030, CON-Z3-PS-02-ME-0010 FF+3d, CON-Z3-PS-02-AR-0010 | 21.8d | 0d | Common Labor / Helper [26 h]; Scaffolder [52 h]; Painter [78 h] | 13,920.74 | 1.3.8.30 | CONS | CONS | ZONE-3 | REALM | Picnic Shelter |

Notes:
- CON-Z3-PS-01-ME-0010: Expenses: (New Expense Item) 40602.2
- CON-Z3-PS-01-ME-0020: Expenses: (New Expense Item) 12180.6
- CON-Z3-PS-01-ME-0030: Expenses: (New Expense Item) 12180.6
- CON-Z3-PS-01-ME-0040: Expenses: (New Expense Item) 8120.43
- CON-Z3-PS-01-ME-0050: Expenses: (New Expense Item) 8120.43
- CON-Z3-PS-01-EW-0010: Expenses: (New Expense Item) 5800.31
- CON-Z3-PS-01-EW-0020: Expenses: (New Expense Item) 8700.46
- CON-Z3-PS-01-EW-0030: Expenses: (New Expense Item) 5800.31
- CON-Z3-PS-01-EW-0040: Expenses: (New Expense Item) 23201.2
- CON-Z3-PS-01-EW-0050: Expenses: (New Expense Item) 14500.8
- CON-Z3-PS-01-TC-0010: Expenses: (New Expense Item) 24361.3
- CON-Z3-PS-01-TC-0020: Expenses: (New Expense Item) 10440.5
- CON-Z3-PS-02-CW-0020: Expenses: (New Expense Item) 4640.25
- CON-Z3-PS-02-CW-0030: Expenses: (New Expense Item) 6960.37
- CON-Z3-PS-02-AR-0010: Expenses: (New Expense Item) 9280.49
- CON-Z3-PS-02-AR-0020: Expenses: (New Expense Item) 18561
- CON-Z3-PS-02-AR-0030: Expenses: (New Expense Item) 4640.25
- CON-Z3-PS-02-AR-0040: Expenses: (New Expense Item) 13920.7

| ID | WBS | Activity | Type | Duration | Start | Finish | Predecessors | Total float | Free float | Resources | Cost | RPI_P2 - BOQ ITEMS | RPI_P2 - CONSTRUCTION | RPI_P2 - PHASE | RPI_P2 - ZONES | RPI_P2 - AREAS | RPI_P2 - BUILDINGS |
| --- | --- | --- | --- | --- | --- | --- | --- | --- | --- | --- | --- | --- | --- | --- | --- | --- | --- |
|  | 3 | **Mechanical Works** |  |  | 2017-06-19 | 2017-09-24 |  |  |  |  |  |  |  |  |  |  |  |
| CON-Z3-PS-02-ME-0010 |  | Installation of Potable Water Supply System |  | 25d | 2017-06-19 | 2017-07-23 | CON-Z3-PS-02-AR-0010 | 10.8d | 0d | Plumber [78 h]; Common Labor / Helper [52 h] | 40,602.15 | 1.3.8.30 | CONS | CONS | ZONE-3 | REALM | Picnic Shelter |
| CON-Z3-PS-02-ME-0020 |  | Installation of Waste and Vent Pipes |  | 15d | 2017-07-23 | 2017-08-09 | CON-Z3-PS-02-AR-0040 SS, CON-Z3-PS-02-ME-0010 | 21.8d | 0d | Plumber [52 h]; Common Labor / Helper [52 h] | 12,180.64 | 1.3.8.30 | CONS | CONS | ZONE-3 | REALM | Picnic Shelter |
| CON-Z3-PS-02-ME-0030 |  | Installation of Free Standing Sink with drain |  | 10d | 2017-08-09 | 2017-08-21 | CON-Z3-PS-02-ME-0020 | 21.8d | 0d | Plumber [26 h]; Common Labor / Helper [52 h] | 12,180.64 | 1.3.8.30 | CONS | CONS | ZONE-3 | REALM | Picnic Shelter |
| CON-Z3-PS-02-ME-0040 |  | Instalaltion of Tie in Connection for Water Supply system |  | 12d | 2017-08-21 | 2017-09-09 | CON-Z3-PS-02-ME-0030 | 21.8d | 0d | Plumber [52 h]; Common Labor / Helper [52 h] | 8,120.43 | 1.3.8.30 | CONS | CONS | ZONE-3 | REALM | Picnic Shelter |
| CON-Z3-PS-02-ME-0050 |  | Installation of Tie in Connection for Drainage |  | 12d | 2017-09-09 | 2017-09-24 | CON-Z3-PS-02-ME-0040 | 21.8d | 0d | Plumber [52 h]; Common Labor / Helper [52 h] | 8,120.43 | 1.3.8.30 | CONS | CONS | ZONE-3 | REALM | Picnic Shelter |
|  | 4 | **Electrical Works** |  |  | 2017-07-23 | 2017-10-02 |  |  |  |  |  |  |  |  |  |  |  |
| CON-Z3-PS-02-EW-0010 |  | Instalaltion of Conduits |  | 10d | 2017-07-23 | 2017-08-03 | CON-Z3-PS-02-ME-0010 | 10.8d | 0d | Electrician [78 h]; LC Crew [52 h] | 5,800.31 | 1.3.8.30 | CONS | CONS | ZONE-3 | REALM | Picnic Shelter |
| CON-Z3-PS-02-EW-0020 |  | Installation of Cables |  | 10d | 2017-08-03 | 2017-08-15 | CON-Z3-PS-02-EW-0010 | 10.8d | 0d | Electrician [78 h]; LC Crew [52 h] | 8,700.46 | 1.3.8.30 | CONS | CONS | ZONE-3 | REALM | Picnic Shelter |
| CON-Z3-PS-02-EW-0030 |  | Installation of Junction Boxes |  | 8d | 2017-08-15 | 2017-08-24 | CON-Z3-PS-02-EW-0020 | 10.8d | 0d | Electrician [78 h]; LC Crew [52 h] | 5,800.31 | 1.3.8.30 | CONS | CONS | ZONE-3 | REALM | Picnic Shelter |
| CON-Z3-PS-02-EW-0040 |  | Installation of receptacle outlets and wiring devices |  | 12d | 2017-08-24 | 2017-09-12 | CON-Z3-PS-02-EW-0030 | 10.8d | 0d | Electrician [78 h]; LC Crew [52 h] | 23,201.23 | 1.3.8.30 | CONS | CONS | ZONE-3 | REALM | Picnic Shelter |
| CON-Z3-PS-02-EW-0050 |  | Installation of Internal and External Lighting Fixures |  | 16d | 2017-09-12 | 2017-10-02 | CON-Z3-PS-02-EW-0040 | 10.8d | 0d | Electrician [78 h]; LC Crew [52 h] | 14,500.77 | 1.3.8.30 | CONS | CONS | ZONE-3 | REALM | Picnic Shelter |
|  | 6 | **Testing and Precommissioning** |  |  | 2017-09-24 | 2017-10-21 |  |  |  |  |  |  |  |  |  |  |  |
| CON-Z3-PS-02-TC-0010 |  | Testing and Precommissioning of Plumbing Work |  | 12d | 2017-09-24 | 2017-10-08 | CON-Z3-PS-02-ME-0040, CON-Z3-PS-02-ME-0010, CON-Z3-PS-02-ME-0050 | 21.8d | 11d | Plumber [78 h]; Common Labor / Helper [52 h] | 24,361.29 | 1.3.8.30 | CONS | CONS | ZONE-3 | REALM | Picnic Shelter |
| CON-Z3-PS-02-TC-0020 |  | Testing and Precommissioning of Electrical Work |  | 16d | 2017-10-02 | 2017-10-21 | CON-Z3-PS-02-EW-0050 | 10.8d | 0d | Electrician [78 h]; Common Labor / Helper [26 h] | 10,440.55 | 1.3.8.30 | CONS | CONS | ZONE-3 | REALM | Picnic Shelter |
| CON-Z3-PS-02-TC-0030 |  | Finish of Pinic Shelters - Area - 2 (PS-07 to PS-12) | milestone | 0d | 2017-10-21 | 2017-10-21 | CON-Z3-PS-02-TC-0010, CON-Z3-PS-02-TC-0020 | 10.8d | 10.6d |  |  | 1.3.8.30 | CONS | CONS | ZONE-3 | REALM | Picnic Shelter |
|  | 2 | **Pinic Shelters - Area - 3 (PS-13 to PS-18)** |  |  | 2017-04-27 | 2017-10-14 |  |  |  |  |  |  |  |  |  |  |  |
|  | 1 | **Civil / Structural Works** |  |  | 2017-04-27 | 2017-06-07 |  |  |  |  |  |  |  |  |  |  |  |
| CON-Z3-PS-03-CW-0010 |  | Start of Pinic Shelters - Area - 3 (PS-13 to PS-18) | milestone | 0d | 2017-04-27 | 2017-04-27 | CON-Z3-PS-02-CW-0010 FS+10d | 4.8d | 0d |  |  | 1.3.8.30 | CONS | CONS | ZONE-3 | REALM | Picnic Shelter |
| CON-Z3-PS-03-CW-0020 |  | General Backfilling |  | 15d | 2017-04-27 | 2017-05-15 | CON-Z3-PS-03-CW-0010 | 16.8d | 0d | Common Labor / Helper [78 h]; Operator - Loader [26 h]; Driver - Dump Truck [26 h]; Operator - Bobcat [26 h]; Operator - Roller-Compactor (2~10 Ton) [26 h]; Operator - Roller (25 Ton) [26 h]; Driver - Water Tanker [26 h]; Loader [28 h]; Dump Truck [28 h]; Bobcat [28 h]; Roller-Compactor (2~10 Ton) [28 h]; Roller-Compactor (25 Ton) [28 h]; Water Tanker [28 h] | 4,640.25 | 1.3.8.30 | CONS | CONS | ZONE-3 | REALM | Picnic Shelter |
| CON-Z3-PS-03-CW-0030 |  | Installation of Reinforced Slab on Grade |  | 20d | 2017-05-15 | 2017-06-07 | CON-Z3-PS-03-CW-0020 | 16.8d | 0d | Steel Fixer [52 h]; Shuttering Carpenter [78 h]; Concrete Mason [78 h]; Common Labor / Helper [78 h] | 6,960.37 | 1.3.8.30 | CONS | CONS | ZONE-3 | REALM | Picnic Shelter |
|  | 2 | **Architectural Works & Finishes** |  |  | 2017-05-20 | 2017-08-20 |  |  |  |  |  |  |  |  |  |  |  |
| CON-Z3-PS-03-AR-0010 |  | Plastering Work |  | 20d | 2017-05-20 | 2017-06-12 | CON-Z3-PS-03-CW-0030 SS+4d | 16.8d | 0d | Concrete Mason [78 h]; Common Labor / Helper [26 h]; Scaffolder [26 h]; Finishing Work Crew [52 h] | 9,280.49 | 1.3.8.30 | CONS | CONS | ZONE-3 | REALM | Picnic Shelter |
| CON-Z3-PS-03-AR-0020 |  | Installation of Composite wood roof trellis and other wood works |  | 15d | 2017-06-12 | 2017-07-04 | CON-Z3-PS-03-AR-0010 | 27.8d | 0d | Shuttering Carpenter [52 h]; Common Labor / Helper [78 h]; Scaffolder [52 h]; Wood Works Crew [52 h] | 18,560.98 | 1.3.8.30 | CONS | CONS | ZONE-3 | REALM | Picnic Shelter |
| CON-Z3-PS-03-AR-0030 |  | Installation of broom finish for the floor area |  | 10d | 2017-07-04 | 2017-07-16 | CON-Z3-PS-03-AR-0020 | 27.8d | 0d | Common Labor / Helper [52 h]; Finishing Work Crew [52 h] | 4,640.25 | 1.3.8.30 | CONS | CONS | ZONE-3 | REALM | Picnic Shelter |
| CON-Z3-PS-03-AR-0040 |  | Painting Work |  | 30d | 2017-07-16 | 2017-08-20 | CON-Z3-PS-03-AR-0030, CON-Z3-PS-03-AR-0010, CON-Z3-PS-03-ME-0010 FF+3d | 27.8d | 0d | Common Labor / Helper [26 h]; Scaffolder [52 h]; Painter [78 h] | 13,920.74 | 1.3.8.30 | CONS | CONS | ZONE-3 | REALM | Picnic Shelter |

Notes:
- CON-Z3-PS-02-ME-0010: Expenses: (New Expense Item) 40602.2
- CON-Z3-PS-02-ME-0020: Expenses: (New Expense Item) 12180.6
- CON-Z3-PS-02-ME-0030: Expenses: (New Expense Item) 12180.6
- CON-Z3-PS-02-ME-0040: Expenses: (New Expense Item) 8120.43
- CON-Z3-PS-02-ME-0050: Expenses: (New Expense Item) 8120.43
- CON-Z3-PS-02-EW-0010: Expenses: (New Expense Item) 5800.31
- CON-Z3-PS-02-EW-0020: Expenses: (New Expense Item) 8700.46
- CON-Z3-PS-02-EW-0030: Expenses: (New Expense Item) 5800.31
- CON-Z3-PS-02-EW-0040: Expenses: (New Expense Item) 23201.2
- CON-Z3-PS-02-EW-0050: Expenses: (New Expense Item) 14500.8
- CON-Z3-PS-02-TC-0010: Expenses: (New Expense Item) 24361.3
- CON-Z3-PS-02-TC-0020: Expenses: (New Expense Item) 10440.5
- CON-Z3-PS-03-CW-0020: Expenses: (New Expense Item) 4640.25
- CON-Z3-PS-03-CW-0030: Expenses: (New Expense Item) 6960.37
- CON-Z3-PS-03-AR-0010: Expenses: (New Expense Item) 9280.49
- CON-Z3-PS-03-AR-0020: Expenses: (New Expense Item) 18561
- CON-Z3-PS-03-AR-0030: Expenses: (New Expense Item) 4640.25
- CON-Z3-PS-03-AR-0040: Expenses: (New Expense Item) 13920.7

| ID | WBS | Activity | Type | Duration | Start | Finish | Predecessors | Total float | Free float | Resources | Cost | RPI_P2 - BOQ ITEMS | RPI_P2 - CONSTRUCTION | RPI_P2 - PHASE | RPI_P2 - ZONES | RPI_P2 - AREAS | RPI_P2 - BUILDINGS |
| --- | --- | --- | --- | --- | --- | --- | --- | --- | --- | --- | --- | --- | --- | --- | --- | --- | --- |
|  | 3 | **Mechanical Works** |  |  | 2017-06-12 | 2017-09-16 |  |  |  |  |  |  |  |  |  |  |  |
| CON-Z3-PS-03-ME-0010 |  | Installation of Potable Water Supply System |  | 25d | 2017-06-12 | 2017-07-16 | CON-Z3-PS-03-AR-0010 | 16.8d | 0d | Plumber [78 h]; Common Labor / Helper [52 h] | 40,602.15 | 1.3.8.30 | CONS | CONS | ZONE-3 | REALM | Picnic Shelter |
| CON-Z3-PS-03-ME-0020 |  | Installation of Waste and Vent Pipes |  | 15d | 2017-07-16 | 2017-08-02 | CON-Z3-PS-03-AR-0040 SS, CON-Z3-PS-03-ME-0010 | 27.8d | 0d | Plumber [52 h]; Common Labor / Helper [52 h] | 12,180.64 | 1.3.8.30 | CONS | CONS | ZONE-3 | REALM | Picnic Shelter |
| CON-Z3-PS-03-ME-0030 |  | Installation of Free Standing Sink with drain |  | 10d | 2017-08-02 | 2017-08-14 | CON-Z3-PS-03-ME-0020 | 27.8d | 0d | Plumber [26 h]; Common Labor / Helper [52 h] | 12,180.64 | 1.3.8.30 | CONS | CONS | ZONE-3 | REALM | Picnic Shelter |
| CON-Z3-PS-03-ME-0040 |  | Instalaltion of Tie in Connection for Water Supply system |  | 12d | 2017-08-14 | 2017-08-28 | CON-Z3-PS-03-ME-0030 | 27.8d | 0d | Plumber [52 h]; Common Labor / Helper [52 h] | 8,120.43 | 1.3.8.30 | CONS | CONS | ZONE-3 | REALM | Picnic Shelter |
| CON-Z3-PS-03-ME-0050 |  | Installation of Tie in Connection for Drainage |  | 12d | 2017-08-28 | 2017-09-16 | CON-Z3-PS-03-ME-0040 | 27.8d | 0d | Plumber [52 h]; Common Labor / Helper [52 h] | 8,120.43 | 1.3.8.30 | CONS | CONS | ZONE-3 | REALM | Picnic Shelter |
|  | 4 | **Electrical Works** |  |  | 2017-07-16 | 2017-09-25 |  |  |  |  |  |  |  |  |  |  |  |
| CON-Z3-PS-03-EW-0010 |  | Instalaltion of Conduits |  | 10d | 2017-07-16 | 2017-07-27 | CON-Z3-PS-03-ME-0010 | 16.8d | 0d | Electrician [78 h]; LC Crew [52 h] | 5,800.31 | 1.3.8.30 | CONS | CONS | ZONE-3 | REALM | Picnic Shelter |
| CON-Z3-PS-03-EW-0020 |  | Installation of Cables |  | 10d | 2017-07-27 | 2017-08-08 | CON-Z3-PS-03-EW-0010 | 16.8d | 0d | Electrician [78 h]; LC Crew [52 h] | 8,700.46 | 1.3.8.30 | CONS | CONS | ZONE-3 | REALM | Picnic Shelter |
| CON-Z3-PS-03-EW-0030 |  | Installation of Junction Boxes |  | 8d | 2017-08-08 | 2017-08-17 | CON-Z3-PS-03-EW-0020 | 16.8d | 0d | Electrician [78 h]; LC Crew [52 h] | 5,800.31 | 1.3.8.30 | CONS | CONS | ZONE-3 | REALM | Picnic Shelter |
| CON-Z3-PS-03-EW-0040 |  | Installation of receptacle outlets and wiring devices |  | 12d | 2017-08-17 | 2017-09-05 | PR-Z3-EW-ME-61-0080, CON-Z3-PS-03-EW-0030 | 16.8d | 0d | Electrician [78 h]; LC Crew [52 h] | 23,201.23 | 1.3.8.30 | CONS | CONS | ZONE-3 | REALM | Picnic Shelter |
| CON-Z3-PS-03-EW-0050 |  | Installation of Internal and External Lighting Fixures |  | 16d | 2017-09-05 | 2017-09-25 | CON-Z3-PS-03-EW-0040 | 16.8d | 0d | Electrician [78 h]; LC Crew [52 h] | 14,500.77 | 1.3.8.30 | CONS | CONS | ZONE-3 | REALM | Picnic Shelter |
|  | 6 | **Testing and Precommissioning** |  |  | 2017-09-16 | 2017-10-14 |  |  |  |  |  |  |  |  |  |  |  |
| CON-Z3-PS-03-TC-0010 |  | Testing and Precommissioning of Plumbing Work |  | 12d | 2017-09-16 | 2017-10-01 | CON-Z3-PS-03-ME-0040, CON-Z3-PS-03-ME-0040 FF, CON-Z3-PS-03-ME-0020, CON-Z3-PS-03-ME-0010, CON-Z3-PS-03-ME-0050 | 27.8d | 11d | Plumber [78 h]; Common Labor / Helper [52 h] | 24,361.29 | 1.3.8.30 | CONS | CONS | ZONE-3 | REALM | Picnic Shelter |
| CON-Z3-PS-03-TC-0020 |  | Testing and Precommissioning of Electrical Work |  | 16d | 2017-09-25 | 2017-10-14 | CON-Z3-PS-03-EW-0050 | 16.8d | 0d | Electrician [78 h]; Common Labor / Helper [26 h] | 10,440.55 | 1.3.8.30 | CONS | CONS | ZONE-3 | REALM | Picnic Shelter |
| CON-Z3-PS-03-TC-0030 |  | Finish of Pinic Shelters - Area - 3 (PS-13 to PS-18) | milestone | 0d | 2017-10-14 | 2017-10-14 | CON-Z3-PS-03-TC-0010, CON-Z3-PS-03-TC-0020 | 16.8d | 16.6d |  |  | 1.3.8.30 | CONS | CONS | ZONE-3 | REALM | Picnic Shelter |
|  | 3 | **Pinic Shelters - Area - 4 (PS-19 to PS-24)** |  |  | 2017-05-09 | 2017-10-25 |  |  |  |  |  |  |  |  |  |  |  |
|  | 1 | **Civil / Structural Works** |  |  | 2017-05-09 | 2017-06-19 |  |  |  |  |  |  |  |  |  |  |  |
| CON-Z3-PS-04-CW-0010 |  | Start of Pinic Shelters - Area - 4 (PS-19 to PS-24) | milestone | 0d | 2017-05-09 | 2017-05-09 | CON-Z3-PS-03-CW-0010 FS+10d | 4.8d | 0d |  |  | 1.3.8.30 | CONS | CONS | ZONE-3 | REALM | Picnic Shelter |
| CON-Z3-PS-04-CW-0020 |  | General Backfilling |  | 15d | 2017-05-09 | 2017-05-27 | CON-Z3-PS-04-CW-0010 | 6.8d | 0d | Common Labor / Helper [78 h]; Operator - Loader [26 h]; Driver - Dump Truck [26 h]; Operator - Bobcat [26 h]; Operator - Roller-Compactor (2~10 Ton) [26 h]; Operator - Roller (25 Ton) [26 h]; Driver - Water Tanker [26 h]; Loader [28 h]; Dump Truck [28 h]; Bobcat [28 h]; Roller-Compactor (2~10 Ton) [28 h]; Roller-Compactor (25 Ton) [28 h]; Water Tanker [28 h] | 4,640.25 | 1.3.8.30 | CONS | CONS | ZONE-3 | REALM | Picnic Shelter |
| CON-Z3-PS-04-CW-0030 |  | Installation of Reinforced Slab on Grade |  | 20d | 2017-05-27 | 2017-06-19 | CON-Z3-PS-04-CW-0020 | 6.8d | 0d | Steel Fixer [52 h]; Shuttering Carpenter [78 h]; Concrete Mason [78 h]; Common Labor / Helper [78 h] | 6,960.37 | 1.3.8.30 | CONS | CONS | ZONE-3 | REALM | Picnic Shelter |
|  | 2 | **Architectural Works & Finishes** |  |  | 2017-05-31 | 2017-08-13 |  |  |  |  |  |  |  |  |  |  |  |
| CON-Z3-PS-04-AR-0010 |  | Plastering Work |  | 20d | 2017-05-31 | 2017-06-24 | CON-Z3-PS-04-CW-0030 SS+4d | 6.8d | 0d | Concrete Mason [78 h]; Common Labor / Helper [26 h]; Scaffolder [26 h]; Finishing Work Crew [52 h] | 9,280.49 | 1.3.8.30 | CONS | CONS | ZONE-3 | REALM | Picnic Shelter |
| CON-Z3-PS-04-AR-0020 |  | Installation of Composite wood roof trellis and other wood works |  | 15d | 2017-06-05 | 2017-06-22 | CON-Z3-PS-04-AR-0010 SS+4d | 33.8d | 0d | Shuttering Carpenter [52 h]; Common Labor / Helper [78 h]; Scaffolder [52 h]; Wood Works Crew [52 h] | 18,560.98 | 1.3.8.30 | CONS | CONS | ZONE-3 | REALM | Picnic Shelter |
| CON-Z3-PS-04-AR-0030 |  | Installation of broom finish for the floor area |  | 10d | 2017-06-22 | 2017-07-09 | CON-Z3-PS-04-AR-0020 | 33.8d | 0d | Common Labor / Helper [52 h]; Finishing Work Crew [52 h] | 4,640.25 | 1.3.8.30 | CONS | CONS | ZONE-3 | REALM | Picnic Shelter |
| CON-Z3-PS-04-AR-0040 |  | Painting Work |  | 30d | 2017-07-09 | 2017-08-13 | CON-Z3-PS-04-AR-0030, CON-Z3-PS-04-ME-0010 FF+3d, CON-Z3-PS-04-AR-0010 | 33.8d | 16d | Common Labor / Helper [26 h]; Scaffolder [52 h]; Painter [78 h] | 13,920.74 | 1.3.8.30 | CONS | CONS | ZONE-3 | REALM | Picnic Shelter |

Notes:
- CON-Z3-PS-03-ME-0010: Expenses: (New Expense Item) 40602.2
- CON-Z3-PS-03-ME-0020: Expenses: (New Expense Item) 12180.6
- CON-Z3-PS-03-ME-0030: Expenses: (New Expense Item) 12180.6
- CON-Z3-PS-03-ME-0040: Expenses: (New Expense Item) 8120.43
- CON-Z3-PS-03-ME-0050: Expenses: (New Expense Item) 8120.43
- CON-Z3-PS-03-EW-0010: Expenses: (New Expense Item) 5800.31
- CON-Z3-PS-03-EW-0020: Expenses: (New Expense Item) 8700.46
- CON-Z3-PS-03-EW-0030: Expenses: (New Expense Item) 5800.31
- CON-Z3-PS-03-EW-0040: Expenses: (New Expense Item) 23201.2
- CON-Z3-PS-03-EW-0050: Expenses: (New Expense Item) 14500.8
- CON-Z3-PS-03-TC-0010: Expenses: (New Expense Item) 24361.3
- CON-Z3-PS-03-TC-0020: Expenses: (New Expense Item) 10440.5
- CON-Z3-PS-04-CW-0020: Expenses: (New Expense Item) 4640.25
- CON-Z3-PS-04-CW-0030: Expenses: (New Expense Item) 6960.37
- CON-Z3-PS-04-AR-0010: Expenses: (New Expense Item) 9280.49
- CON-Z3-PS-04-AR-0020: Expenses: (New Expense Item) 18561
- CON-Z3-PS-04-AR-0030: Expenses: (New Expense Item) 4640.25
- CON-Z3-PS-04-AR-0040: Expenses: (New Expense Item) 13920.7

| ID | WBS | Activity | Type | Duration | Start | Finish | Predecessors | Total float | Free float | Resources | Cost | RPI_P2 - BOQ ITEMS | RPI_P2 - CONSTRUCTION | RPI_P2 - PHASE | RPI_P2 - ZONES | RPI_P2 - AREAS | RPI_P2 - BUILDINGS |
| --- | --- | --- | --- | --- | --- | --- | --- | --- | --- | --- | --- | --- | --- | --- | --- | --- | --- |
|  | 3 | **Mechanical Works** |  |  | 2017-06-24 | 2017-09-28 |  |  |  |  |  |  |  |  |  |  |  |
| CON-Z3-PS-04-ME-0010 |  | Installation of Potable Water Supply System |  | 25d | 2017-06-24 | 2017-07-27 | CON-Z3-PS-04-AR-0010 | 6.8d | 0d | Plumber [78 h]; Common Labor / Helper [52 h] | 40,602.15 | 1.3.8.30 | CONS | CONS | ZONE-3 | REALM | Picnic Shelter |
| CON-Z3-PS-04-ME-0020 |  | Installation of Waste and Vent Pipes |  | 15d | 2017-07-27 | 2017-08-14 | CON-Z3-PS-04-ME-0010, CON-Z3-PS-04-AR-0040 SS | 17.8d | 0d | Plumber [52 h]; Common Labor / Helper [52 h] | 12,180.64 | 1.3.8.30 | CONS | CONS | ZONE-3 | REALM | Picnic Shelter |
| CON-Z3-PS-04-ME-0030 |  | Installation of Free Standing Sink with drain |  | 10d | 2017-08-14 | 2017-08-26 | CON-Z3-PS-04-ME-0020 | 17.8d | 0d | Plumber [26 h]; Common Labor / Helper [52 h] | 12,180.64 | 1.3.8.30 | CONS | CONS | ZONE-3 | REALM | Picnic Shelter |
| CON-Z3-PS-04-ME-0040 |  | Instalaltion of Tie in Connection for Water Supply system |  | 12d | 2017-08-26 | 2017-09-13 | CON-Z3-PS-04-ME-0030 | 17.8d | 0d | Plumber [52 h]; Common Labor / Helper [52 h] | 8,120.43 | 1.3.8.30 | CONS | CONS | ZONE-3 | REALM | Picnic Shelter |
| CON-Z3-PS-04-ME-0050 |  | Installation of Tie in Connection for Drainage |  | 12d | 2017-09-13 | 2017-09-28 | CON-Z3-PS-04-ME-0040 | 17.8d | 0d | Plumber [52 h]; Common Labor / Helper [52 h] | 8,120.43 | 1.3.8.30 | CONS | CONS | ZONE-3 | REALM | Picnic Shelter |
|  | 4 | **Electrical Works** |  |  | 2017-07-27 | 2017-10-07 |  |  |  |  |  |  |  |  |  |  |  |
| CON-Z3-PS-04-EW-0010 |  | Instalaltion of Conduits |  | 10d | 2017-07-27 | 2017-08-08 | CON-Z3-PS-04-ME-0010 | 6.8d | 0d | Electrician [78 h]; LC Crew [52 h] | 5,800.31 | 1.3.8.30 | CONS | CONS | ZONE-3 | REALM | Picnic Shelter |
| CON-Z3-PS-04-EW-0020 |  | Installation of Cables |  | 10d | 2017-08-08 | 2017-08-20 | CON-Z3-PS-04-EW-0010 | 6.8d | 0d | Electrician [78 h]; LC Crew [52 h] | 8,700.46 | 1.3.8.30 | CONS | CONS | ZONE-3 | REALM | Picnic Shelter |
| CON-Z3-PS-04-EW-0030 |  | Installation of Junction Boxes |  | 8d | 2017-08-20 | 2017-08-29 | CON-Z3-PS-04-EW-0020 | 6.8d | 0d | Electrician [78 h]; LC Crew [52 h] | 5,800.31 | 1.3.8.30 | CONS | CONS | ZONE-3 | REALM | Picnic Shelter |
| CON-Z3-PS-04-EW-0040 |  | Installation of receptacle outlets and wiring devices |  | 12d | 2017-08-29 | 2017-09-17 | CON-Z3-PS-04-EW-0030 | 6.8d | 0d | Electrician [78 h]; LC Crew [52 h] | 23,201.23 | 1.3.8.30 | CONS | CONS | ZONE-3 | REALM | Picnic Shelter |
| CON-Z3-PS-04-EW-0050 |  | Installation of Internal and External Lighting Fixures |  | 16d | 2017-09-17 | 2017-10-07 | CON-Z3-PS-04-EW-0040 | 6.8d | 0d | Electrician [78 h]; LC Crew [52 h] | 14,500.77 | 1.3.8.30 | CONS | CONS | ZONE-3 | REALM | Picnic Shelter |
|  | 6 | **Testing and Precommissioning** |  |  | 2017-09-28 | 2017-10-25 |  |  |  |  |  |  |  |  |  |  |  |
| CON-Z3-PS-04-TC-0010 |  | Testing and Precommissioning of Plumbing Work |  | 12d | 2017-09-28 | 2017-10-12 | CON-Z3-PS-04-ME-0020, CON-Z3-PS-04-ME-0040, CON-Z3-PS-04-ME-0010, CON-Z3-PS-04-ME-0050 | 17.8d | 11d | Plumber [78 h]; Common Labor / Helper [52 h] | 24,361.29 | 1.3.8.30 | CONS | CONS | ZONE-3 | REALM | Picnic Shelter |
| CON-Z3-PS-04-TC-0020 |  | Testing and Precommissioning of Electrical Work |  | 16d | 2017-10-07 | 2017-10-25 | CON-Z3-PS-04-EW-0050 | 6.8d | 0d | Electrician [78 h]; Common Labor / Helper [26 h] | 10,440.55 | 1.3.8.30 | CONS | CONS | ZONE-3 | REALM | Picnic Shelter |
| CON-Z3-PS-04-TC-0030 |  | Finish of Pinic Shelters - Area - 4 (PS-19 to PS-24) | milestone | 0d | 2017-10-25 | 2017-10-25 | CON-Z3-PS-04-TC-0010, CON-Z3-PS-04-TC-0020 | 6.8d | 6.6d |  |  | 1.3.8.30 | CONS | CONS | ZONE-3 | REALM | Picnic Shelter |
|  | 4 | **Pinic Shelters - Area - 5 (PS-25 to PS-30)** |  |  | 2017-05-21 | 2017-10-28 |  |  |  |  |  |  |  |  |  |  |  |
|  | 1 | **Civil / Structural Works** |  |  | 2017-05-21 | 2017-07-05 |  |  |  |  |  |  |  |  |  |  |  |
| CON-Z3-PS-05-CW-0010 |  | Start of Pinic Shelters - Area - 5 (PS-25 to PS-30) | milestone | 0d | 2017-05-21 | 2017-05-21 | CON-Z3-PS-04-CW-0010 FS+10d | 4.8d | 0d |  |  | 1.3.8.30 | CONS | CONS | ZONE-3 | REALM | Picnic Shelter |
| CON-Z3-PS-05-CW-0020 |  | General Backfilling |  | 15d | 2017-05-21 | 2017-06-07 | CON-Z3-PS-05-CW-0010 | 4.8d | 0d | Operator - Bobcat [26 h]; Operator - Roller-Compactor (2~10 Ton) [26 h]; Operator - Roller (25 Ton) [26 h]; Driver - Water Tanker [26 h]; Loader [28 h]; Dump Truck [28 h]; Bobcat [28 h]; Roller-Compactor (2~10 Ton) [28 h]; Roller-Compactor (25 Ton) [28 h]; Water Tanker [28 h]; Common Labor / Helper [78 h]; Operator - Loader [26 h]; Driver - Dump Truck [26 h] | 4,640.25 | 1.3.8.30 | CONS | CONS | ZONE-3 | REALM | Picnic Shelter |
| CON-Z3-PS-05-CW-0030 |  | Installation of Reinforced Slab on Grade |  | 20d | 2017-06-07 | 2017-07-05 | CON-Z3-PS-05-CW-0020 | 4.8d | 0d | Steel Fixer [52 h]; Shuttering Carpenter [78 h]; Concrete Mason [78 h]; Common Labor / Helper [78 h] | 6,960.37 | 1.3.8.30 | CONS | CONS | ZONE-3 | REALM | Picnic Shelter |
|  | 2 | **Architectural Works & Finishes** |  |  | 2017-06-12 | 2017-08-24 |  |  |  |  |  |  |  |  |  |  |  |
| CON-Z3-PS-05-AR-0010 |  | Plastering Work |  | 20d | 2017-06-12 | 2017-07-10 | CON-Z3-PS-05-CW-0030 SS+4d | 4.8d | 0d | Concrete Mason [78 h]; Common Labor / Helper [26 h]; Scaffolder [26 h]; Finishing Work Crew [52 h] | 9,280.49 | 1.3.8.30 | CONS | CONS | ZONE-3 | REALM | Picnic Shelter |
| CON-Z3-PS-05-AR-0020 |  | Installation of Composite wood roof trellis and other wood works |  | 15d | 2017-06-17 | 2017-07-09 | CON-Z3-PS-05-AR-0010 SS+4d | 23.8d | 0d | Shuttering Carpenter [52 h]; Common Labor / Helper [78 h]; Scaffolder [52 h]; Wood Works Crew [52 h] | 18,560.98 | 1.3.8.30 | CONS | CONS | ZONE-3 | REALM | Picnic Shelter |
| CON-Z3-PS-05-AR-0030 |  | Installation of broom finish for the floor area |  | 10d | 2017-07-09 | 2017-07-20 | CON-Z3-PS-05-AR-0020 | 23.8d | 0d | Common Labor / Helper [52 h]; Finishing Work Crew [52 h] | 4,640.25 | 1.3.8.30 | CONS | CONS | ZONE-3 | REALM | Picnic Shelter |
| CON-Z3-PS-05-AR-0040 |  | Painting Work |  | 30d | 2017-07-20 | 2017-08-24 | CON-Z3-PS-05-AR-0010, CON-Z3-PS-05-ME-0010 FF+3d, CON-Z3-PS-05-AR-0030 | 23.8d | 8d | Common Labor / Helper [26 h]; Scaffolder [52 h]; Painter [78 h] | 13,920.74 | 1.3.8.30 | CONS | CONS | ZONE-3 | REALM | Picnic Shelter |

Notes:
- CON-Z3-PS-04-ME-0010: Expenses: (New Expense Item) 40602.2
- CON-Z3-PS-04-ME-0020: Expenses: (New Expense Item) 12180.6
- CON-Z3-PS-04-ME-0030: Expenses: (New Expense Item) 12180.6
- CON-Z3-PS-04-ME-0040: Expenses: (New Expense Item) 8120.43
- CON-Z3-PS-04-ME-0050: Expenses: (New Expense Item) 8120.43
- CON-Z3-PS-04-EW-0010: Expenses: (New Expense Item) 5800.31
- CON-Z3-PS-04-EW-0020: Expenses: (New Expense Item) 8700.46
- CON-Z3-PS-04-EW-0030: Expenses: (New Expense Item) 5800.31
- CON-Z3-PS-04-EW-0040: Expenses: (New Expense Item) 23201.2
- CON-Z3-PS-04-EW-0050: Expenses: (New Expense Item) 14500.8
- CON-Z3-PS-04-TC-0010: Expenses: (New Expense Item) 24361.3
- CON-Z3-PS-04-TC-0020: Expenses: (New Expense Item) 10440.5
- CON-Z3-PS-05-CW-0020: Expenses: (New Expense Item) 4640.25
- CON-Z3-PS-05-CW-0030: Expenses: (New Expense Item) 6960.37
- CON-Z3-PS-05-AR-0010: Expenses: (New Expense Item) 9280.49
- CON-Z3-PS-05-AR-0020: Expenses: (New Expense Item) 18561
- CON-Z3-PS-05-AR-0030: Expenses: (New Expense Item) 4640.25
- CON-Z3-PS-05-AR-0040: Expenses: (New Expense Item) 13920.7

| ID | WBS | Activity | Type | Duration | Start | Finish | Predecessors | Total float | Free float | Resources | Cost | RPI_P2 - BOQ ITEMS | RPI_P2 - CONSTRUCTION | RPI_P2 - PHASE | RPI_P2 - ZONES | RPI_P2 - AREAS | RPI_P2 - BUILDINGS |
| --- | --- | --- | --- | --- | --- | --- | --- | --- | --- | --- | --- | --- | --- | --- | --- | --- | --- |
|  | 3 | **Mechanical Works** |  |  | 2017-07-01 | 2017-10-01 |  |  |  |  |  |  |  |  |  |  |  |
| CON-Z3-PS-05-ME-0010 |  | Installation of Potable Water Supply System |  | 25d | 2017-07-01 | 2017-07-30 | CON-Z3-PS-05-AR-0010 SS+12d | 4.8d | 0d | Plumber [78 h]; Common Labor / Helper [52 h] | 40,602.15 | 1.3.8.30 | CONS | CONS | ZONE-3 | REALM | Picnic Shelter |
| CON-Z3-PS-05-ME-0020 |  | Installation of Waste and Vent Pipes |  | 15d | 2017-07-30 | 2017-08-16 | CON-Z3-PS-05-ME-0010, CON-Z3-PS-05-AR-0040 SS | 15.8d | 0d | Plumber [52 h]; Common Labor / Helper [52 h] | 12,180.64 | 1.3.8.30 | CONS | CONS | ZONE-3 | REALM | Picnic Shelter |
| CON-Z3-PS-05-ME-0030 |  | Installation of Free Standing Sink with drain |  | 10d | 2017-08-16 | 2017-08-28 | CON-Z3-PS-05-ME-0020 | 15.8d | 0d | Plumber [26 h]; Common Labor / Helper [52 h] | 12,180.64 | 1.3.8.30 | CONS | CONS | ZONE-3 | REALM | Picnic Shelter |
| CON-Z3-PS-05-ME-0040 |  | Instalaltion of Tie in Connection for Water Supply system |  | 12d | 2017-08-28 | 2017-09-16 | CON-Z3-PS-05-ME-0030 | 15.8d | 0d | Plumber [52 h]; Common Labor / Helper [52 h] | 8,120.43 | 1.3.8.30 | CONS | CONS | ZONE-3 | REALM | Picnic Shelter |
| CON-Z3-PS-05-ME-0050 |  | Installation of Tie in Connection for Drainage |  | 12d | 2017-09-16 | 2017-10-01 | CON-Z3-PS-05-ME-0040 | 15.8d | 0d | Plumber [52 h]; Common Labor / Helper [52 h] | 8,120.43 | 1.3.8.30 | CONS | CONS | ZONE-3 | REALM | Picnic Shelter |
|  | 4 | **Electrical Works** |  |  | 2017-07-30 | 2017-10-09 |  |  |  |  |  |  |  |  |  |  |  |
| CON-Z3-PS-05-EW-0010 |  | Instalaltion of Conduits |  | 10d | 2017-07-30 | 2017-08-10 | CON-Z3-PS-05-ME-0010 | 4.8d | 0d | Electrician [78 h]; LC Crew [52 h] | 5,800.31 | 1.3.8.30 | CONS | CONS | ZONE-3 | REALM | Picnic Shelter |
| CON-Z3-PS-05-EW-0020 |  | Installation of Cables |  | 10d | 2017-08-10 | 2017-08-22 | CON-Z3-PS-05-EW-0010 | 4.8d | 0d | Electrician [78 h]; LC Crew [52 h] | 8,700.46 | 1.3.8.30 | CONS | CONS | ZONE-3 | REALM | Picnic Shelter |
| CON-Z3-PS-05-EW-0030 |  | Installation of Junction Boxes |  | 8d | 2017-08-22 | 2017-09-05 | CON-Z3-PS-05-EW-0020 | 4.8d | 0d | Electrician [78 h]; LC Crew [52 h] | 5,800.31 | 1.3.8.30 | CONS | CONS | ZONE-3 | REALM | Picnic Shelter |
| CON-Z3-PS-05-EW-0040 |  | Installation of receptacle outlets and wiring devices |  | 12d | 2017-09-05 | 2017-09-19 | CON-Z3-PS-05-EW-0030 | 4.8d | 0d | Electrician [78 h]; LC Crew [52 h] | 23,201.23 | 1.3.8.30 | CONS | CONS | ZONE-3 | REALM | Picnic Shelter |
| CON-Z3-PS-05-EW-0050 |  | Installation of Internal and External Lighting Fixures |  | 16d | 2017-09-19 | 2017-10-09 | CON-Z3-PS-05-EW-0040 | 4.8d | 0d | Electrician [78 h]; LC Crew [52 h] | 14,500.77 | 1.3.8.30 | CONS | CONS | ZONE-3 | REALM | Picnic Shelter |
|  | 6 | **Testing and Precommissioning** |  |  | 2017-10-01 | 2017-10-28 |  |  |  |  |  |  |  |  |  |  |  |
| CON-Z3-PS-05-TC-0010 |  | Testing and Precommissioning of Plumbing Work |  | 12d | 2017-10-01 | 2017-10-15 | CON-Z3-PS-05-ME-0010, CON-Z3-PS-05-ME-0040, CON-Z3-PS-05-ME-0020, CON-Z3-PS-05-ME-0050 | 15.8d | 11d | Plumber [78 h]; Common Labor / Helper [52 h] | 24,361.29 | 1.3.8.30 | CONS | CONS | ZONE-3 | REALM | Picnic Shelter |
| CON-Z3-PS-05-TC-0020 |  | Testing and Precommissioning of Electrical Work |  | 16d | 2017-10-09 | 2017-10-28 | CON-Z3-PS-05-EW-0050 | 4.8d | 0d | Electrician [78 h]; Common Labor / Helper [26 h] | 10,440.55 | 1.3.8.30 | CONS | CONS | ZONE-3 | REALM | Picnic Shelter |
| CON-Z3-PS-05-TC-0030 |  | Finish of Pinic Shelters - Area - 5 (PS-25 to PS-30) | milestone | 0d | 2017-10-28 | 2017-10-28 | CON-Z3-PS-05-TC-0010, CON-Z3-PS-05-TC-0020 | 4.8d | 4.6d |  |  | 1.3.8.30 | CONS | CONS | ZONE-3 | REALM | Picnic Shelter |
|  | 4 | **Fitness Shelters (07 No.s)** |  |  | 2017-01-30 | 2017-10-09 |  |  |  |  |  |  |  |  |  |  |  |
|  | 1 | **Fitness Shelter # 01** |  |  | 2017-01-30 | 2017-06-15 |  |  |  |  |  |  |  |  |  |  |  |
|  | 1 | **Civil / Structural Works** |  |  | 2017-01-30 | 2017-02-28 |  |  |  |  |  |  |  |  |  |  |  |
| CON-Z3-FS-01-CW-0010 |  | Start of Fitness Shelter # 01 | milestone | 0d | 2017-01-30 | 2017-01-30 | CON-CON-CON-CON-0010 FS+145d | 20.8d | 0d |  |  | 1.3.8.40 | CONS | CONS | ZONE-3 | REALM | Fitness S-1 |
| CON-Z3-FS-01-CW-0020 |  | General Backfilling |  | 10d | 2017-01-30 | 2017-02-11 | CON-Z3-FS-01-CW-0010 | 110.8d | 0d | Common Labor / Helper [78 h]; Operator - Loader [26 h]; Driver - Dump Truck [26 h]; Operator - Bobcat [26 h]; Operator - Roller-Compactor (2~10 Ton) [26 h]; Operator - Roller (25 Ton) [26 h]; Driver - Water Tanker [26 h]; Loader [28 h]; Dump Truck [28 h]; Bobcat [28 h]; Roller-Compactor (2~10 Ton) [28 h]; Roller-Compactor (25 Ton) [28 h]; Water Tanker [28 h] | 626.93 | 1.3.8.40 | CONS | CONS | ZONE-3 | REALM | Fitness S-1 |
| CON-Z3-FS-01-CW-0030 |  | Installation of Slab on Garde |  | 15d | 2017-02-11 | 2017-02-28 | CON-Z3-FS-01-CW-0020 | 110.8d | 0d | Steel Fixer [52 h]; Shuttering Carpenter [78 h]; Concrete Mason [78 h]; Common Labor / Helper [78 h] | 940.39 | 1.3.8.40 | CONS | CONS | ZONE-3 | REALM | Fitness S-1 |
|  | 2 | **Architectural & Finishes** |  |  | 2017-02-28 | 2017-06-13 |  |  |  |  |  |  |  |  |  |  |  |
| CON-Z3-FS-01-AR-0010 |  | Plastering Work Internal and External |  | 10d | 2017-02-28 | 2017-03-12 | CON-Z3-FS-01-CW-0030 | 110.8d | 0d | Concrete Mason [78 h]; Common Labor / Helper [26 h]; Scaffolder [26 h]; Finishing Work Crew [52 h] | 940.39 | 1.3.8.40 | CONS | CONS | ZONE-3 | REALM | Fitness S-1 |
| CON-Z3-FS-01-AR-0020 |  | Installation of Concrete Topping and Floor Finishes |  | 10d | 2017-03-12 | 2017-03-23 | CON-Z3-FS-01-AR-0010 | 157.8d | 45.8d | Common Labor / Helper [52 h]; Finishing Work Crew [52 h] | 1,253.85 | 1.3.8.40 | CONS | CONS | ZONE-3 | REALM | Fitness S-1 |
| CON-Z3-FS-01-AR-0030 |  | Installation of Wooden Roof Trellis and other Wood Works |  | 10d | 2017-05-16 | 2017-05-27 | CON-Z3-FS-01-AR-0020, PR-Z3-CW-MS-31-0080 | 112d | 0d | Shuttering Carpenter [52 h]; Common Labor / Helper [78 h]; Scaffolder [52 h]; Wood Works Crew [52 h] | 2,507.71 | 1.3.8.40 | CONS | CONS | ZONE-3 | REALM | Fitness S-1 |
| CON-Z3-FS-01-AR-0040 |  | Painting Work Internal and External |  | 15d | 2017-05-28 | 2017-06-13 | CON-Z3-FS-01-AR-0030, CON-Z3-FS-01-ME-0010 FF+5d | 112d | 2d | Common Labor / Helper [26 h]; Scaffolder [52 h]; Painter [78 h] | 1,567.32 | 1.3.8.40 | CONS | CONS | ZONE-3 | REALM | Fitness S-1 |

Notes:
- CON-Z3-PS-05-ME-0010: Expenses: (New Expense Item) 40602.2
- CON-Z3-PS-05-ME-0020: Expenses: (New Expense Item) 12180.6
- CON-Z3-PS-05-ME-0030: Expenses: (New Expense Item) 12180.6
- CON-Z3-PS-05-ME-0040: Expenses: (New Expense Item) 8120.43
- CON-Z3-PS-05-ME-0050: Expenses: (New Expense Item) 8120.43
- CON-Z3-PS-05-EW-0010: Expenses: (New Expense Item) 5800.31
- CON-Z3-PS-05-EW-0020: Expenses: (New Expense Item) 8700.46
- CON-Z3-PS-05-EW-0030: Expenses: (New Expense Item) 5800.31
- CON-Z3-PS-05-EW-0040: Expenses: (New Expense Item) 23201.2
- CON-Z3-PS-05-EW-0050: Expenses: (New Expense Item) 14500.8
- CON-Z3-PS-05-TC-0010: Expenses: (New Expense Item) 24361.3
- CON-Z3-PS-05-TC-0020: Expenses: (New Expense Item) 10440.5
- CON-Z3-FS-01-CW-0020: Expenses: (New Expense Item) 626.93
- CON-Z3-FS-01-CW-0030: Expenses: (New Expense Item) 940.39
- CON-Z3-FS-01-AR-0010: Expenses: (New Expense Item) 940.39
- CON-Z3-FS-01-AR-0020: Expenses: (New Expense Item) 1253.85
- CON-Z3-FS-01-AR-0030: Expenses: (New Expense Item) 2507.71
- CON-Z3-FS-01-AR-0040: Expenses: (New Expense Item) 1567.32

| ID | WBS | Activity | Type | Duration | Start | Finish | Predecessors | Total float | Free float | Resources | Cost | RPI_P2 - BOQ ITEMS | RPI_P2 - CONSTRUCTION | RPI_P2 - PHASE | RPI_P2 - ZONES | RPI_P2 - AREAS | RPI_P2 - BUILDINGS |
| --- | --- | --- | --- | --- | --- | --- | --- | --- | --- | --- | --- | --- | --- | --- | --- | --- | --- |
|  | 3 | **Mechanical Works** |  |  | 2017-03-12 | 2017-06-01 |  |  |  |  |  |  |  |  |  |  |  |
| CON-Z3-FS-01-ME-0010 |  | Installation of Potable Water Supply System |  | 10d | 2017-03-12 | 2017-03-23 | CON-Z3-FS-01-AR-0010 | 110.8d | 0d | Plumber [78 h]; Common Labor / Helper [52 h] | 3,526.46 | 1.3.8.40 | CONS | CONS | ZONE-3 | REALM | Fitness S-1 |
| CON-Z3-FS-01-ME-0020 |  | Installation of Free Standing Sink with drain |  | 5d | 2017-03-23 | 2017-03-29 | CON-Z3-FS-01-ME-0010 | 150.8d | 40.8d | Plumber [26 h]; Common Labor / Helper [52 h] | 1,567.32 | 1.3.8.40 | CONS | CONS | ZONE-3 | REALM | Fitness S-1 |
| CON-Z3-FS-01-ME-0050 |  | Instalaltion of Tie in Connection for Water Supply system |  | 10d | 2017-03-23 | 2017-04-04 | CON-Z3-FS-01-ME-0010 | 160.8d | 0d | Plumber [52 h]; Common Labor / Helper [52 h] | 783.66 | 1.3.8.40 | CONS | CONS | ZONE-3 | REALM | Fitness S-1 |
| CON-Z3-FS-01-ME-0030 |  | Installation of Drinking Fountain and BBQ Grill |  | 10d | 2017-05-16 | 2017-05-27 | PR-Z3-CW-MS-33-0080, PR-Z3-CW-MS-32-0080, CON-Z3-FS-01-ME-0020 | 110d | 0d | Plumber [26 h]; Common Labor / Helper [52 h] | 1,175.49 | 1.3.8.40 | CONS | CONS | ZONE-3 | REALM | Fitness S-1 |
| CON-Z3-FS-01-ME-0040 |  | Installation of Fire Extinguisher |  | 5d | 2017-05-28 | 2017-06-01 | CON-Z3-FS-01-ME-0030 | 110d | 0d | Common Labor / Helper [52 h] | 783.66 | 1.3.8.40 | CONS | CONS | ZONE-3 | REALM | Fitness S-1 |
|  | 4 | **Electrical Works** |  |  | 2017-03-23 | 2017-05-28 |  |  |  |  |  |  |  |  |  |  |  |
| CON-Z3-FS-01-EW-0010 |  | Instalaltion of Conduits |  | 10d | 2017-03-23 | 2017-04-04 | CON-Z3-FS-01-ME-0010 | 110.8d | 0d | Electrician [78 h]; LC Crew [52 h] | 1,175.49 | 1.3.8.40 | CONS | CONS | ZONE-3 | REALM | Fitness S-1 |
| CON-Z3-FS-01-EW-0020 |  | Installation of Cables |  | 10d | 2017-04-04 | 2017-04-16 | CON-Z3-FS-01-EW-0010 | 110.8d | 0d | Electrician [78 h]; LC Crew [52 h] | 1,959.15 | 1.3.8.40 | CONS | CONS | ZONE-3 | REALM | Fitness S-1 |
| CON-Z3-FS-01-EW-0030 |  | Installation of Junction Boxes |  | 8d | 2017-04-16 | 2017-04-25 | CON-Z3-FS-01-EW-0020 | 110.8d | 0d | Electrician [78 h]; LC Crew [52 h] | 783.66 | 1.3.8.40 | CONS | CONS | ZONE-3 | REALM | Fitness S-1 |
| CON-Z3-FS-01-EW-0040 |  | Installation of receptacle outlets and wiring devices |  | 12d | 2017-04-25 | 2017-05-09 | CON-Z3-FS-01-EW-0030 | 110.8d | 0d | Electrician [78 h]; LC Crew [52 h] | 2,350.98 | 1.3.8.40 | CONS | CONS | ZONE-3 | REALM | Fitness S-1 |
| CON-Z3-FS-01-EW-0050 |  | Installation of Internal and External Lighting Fixures |  | 16d | 2017-05-09 | 2017-05-28 | CON-Z3-FS-01-EW-0040 | 110.8d | 0d | Electrician [78 h]; LC Crew [52 h] | 1,567.32 | 1.3.8.40 | CONS | CONS | ZONE-3 | REALM | Fitness S-1 |
|  | 5 | **External Works** |  |  | 2017-05-09 | 2017-06-06 |  |  |  |  |  |  |  |  |  |  |  |
| CON-Z3-FS-01-EXT-010 |  | Installation of Fitness and Playground Equipments |  | 8d | 2017-05-09 | 2017-05-18 | PR-Z3-LW-LS-120-0080, PR-Z3-LW-LS-119-0080, CON-Z3-FS-01-EW-0050 SS | 134.8d | 24.8d | Common Labor / Helper [78 h] | 2,507.71 | 1.3.8.40 | CONS | CONS | ZONE-3 | REALM | Fitness S-1 |
| CON-Z3-FS-01-EXT-020 |  | Installation of Building Signage |  | 8d | 2017-05-28 | 2017-06-06 | CON-Z3-FS-01-EW-0050 | 118.8d | 8.8d | Shuttering Carpenter [26 h]; Common Labor / Helper [52 h] | 626.93 | 1.3.8.40 | CONS | CONS | ZONE-3 | REALM | Fitness S-1 |
|  | 6 | **Testing and Precommissioning** |  |  | 2017-04-04 | 2017-06-15 |  |  |  |  |  |  |  |  |  |  |  |
| CON-Z3-FS-01-TC-0010 |  | Testing and Precommissioning of Plumbing Work |  | 12d | 2017-04-04 | 2017-04-18 | CON-Z3-FS-01-ME-0010, CON-Z3-FS-01-ME-0050 | 160.8d | 50.8d | Plumber [78 h]; Common Labor / Helper [52 h] | 2,350.98 | 1.3.8.40 | CONS | CONS | ZONE-3 | REALM | Fitness S-1 |
| CON-Z3-FS-01-TC-0030 |  | Testing and Precommissioning of Electrical Work |  | 16d | 2017-05-28 | 2017-06-15 | CON-Z3-FS-01-EW-0050 | 110.8d | 0.8d | Electrician [78 h]; Common Labor / Helper [26 h] | 1,410.59 | 1.3.8.40 | CONS | CONS | ZONE-3 | REALM | Fitness S-1 |
| CON-Z3-FS-01-TC-0020 |  | Testing and Precommissioning of Mechanical Work |  | 12d | 2017-06-03 | 2017-06-15 | CON-Z3-FS-01-ME-0040 | 110d | 0d | Mechanical Technician [78 h]; Common Labor / Helper [26 h]; HVAC Crew [26 h] | 940.39 | 1.3.8.40 | CONS | CONS | ZONE-3 | REALM | Fitness S-1 |
| CON-Z3-FS-01-TC-0040 |  | Finish of Fitness Shelter # 01 | milestone | 0d | 2017-06-15 | 2017-06-15 | CON-Z3-FS-01-EXT-020, CON-Z3-FS-01-TC-0030, CON-Z3-FS-01-TC-0020, CON-Z3-FS-01-EXT-010, CON-Z3-FS-01-AR-0040, CON-Z3-FS-01-TC-0010 | 110d | 109.8d |  |  | 1.3.8.40 | CONS | CONS | ZONE-3 | REALM | Fitness S-1 |
|  | 8 | **Fitness Shelter # 02** |  |  | 2017-02-16 | 2017-07-08 |  |  |  |  |  |  |  |  |  |  |  |
|  | 1 | **Civil / Structural Works** |  |  | 2017-02-16 | 2017-03-18 |  |  |  |  |  |  |  |  |  |  |  |
| CON-Z3-FS-02-CW-0010 |  | Start of Fitness Shelter # 02 | milestone | 0d | 2017-02-16 | 2017-02-16 | CON-Z3-FS-01-CW-0010 FS+15d | 20.8d | 0d |  |  | 1.3.8.40 | CONS | CONS | ZONE-3 | REALM | Fitness S-2 |
| CON-Z3-FS-02-CW-0020 |  | General Backfilling |  | 10d | 2017-02-16 | 2017-02-28 | CON-Z3-FS-02-CW-0010 | 95.8d | 0d | Common Labor / Helper [78 h]; Operator - Loader [26 h]; Driver - Dump Truck [26 h]; Operator - Bobcat [26 h]; Operator - Roller-Compactor (2~10 Ton) [26 h]; Operator - Roller (25 Ton) [26 h]; Driver - Water Tanker [26 h]; Loader [28 h]; Dump Truck [28 h]; Bobcat [28 h]; Roller-Compactor (2~10 Ton) [28 h]; Roller-Compactor (25 Ton) [28 h]; Water Tanker [28 h] | 626.93 | 1.3.8.40 | CONS | CONS | ZONE-3 | REALM | Fitness S-2 |
| CON-Z3-FS-02-CW-0030 |  | Installation of Slab on Garde |  | 15d | 2017-02-28 | 2017-03-18 | CON-Z3-FS-02-CW-0020 | 95.8d | 0d | Steel Fixer [52 h]; Shuttering Carpenter [78 h]; Concrete Mason [78 h]; Common Labor / Helper [78 h] | 940.39 | 1.3.8.40 | CONS | CONS | ZONE-3 | REALM | Fitness S-2 |

Notes:
- CON-Z3-FS-01-ME-0010: Expenses: (New Expense Item) 3526.46
- CON-Z3-FS-01-ME-0020: Expenses: (New Expense Item) 1567.32
- CON-Z3-FS-01-ME-0050: Expenses: (New Expense Item) 783.66
- CON-Z3-FS-01-ME-0030: Expenses: (New Expense Item) 1175.49
- CON-Z3-FS-01-ME-0040: Expenses: (New Expense Item) 783.66
- CON-Z3-FS-01-EW-0010: Expenses: (New Expense Item) 1175.49
- CON-Z3-FS-01-EW-0020: Expenses: (New Expense Item) 1959.15
- CON-Z3-FS-01-EW-0030: Expenses: (New Expense Item) 783.66
- CON-Z3-FS-01-EW-0040: Expenses: (New Expense Item) 2350.98
- CON-Z3-FS-01-EW-0050: Expenses: (New Expense Item) 1567.32
- CON-Z3-FS-01-EXT-010: Expenses: (New Expense Item) 2507.71
- CON-Z3-FS-01-EXT-020: Expenses: (New Expense Item) 626.93
- CON-Z3-FS-01-TC-0010: Expenses: (New Expense Item) 2350.98
- CON-Z3-FS-01-TC-0030: Expenses: (New Expense Item) 1410.59
- CON-Z3-FS-01-TC-0020: Expenses: (New Expense Item) 940.39
- CON-Z3-FS-02-CW-0020: Expenses: (New Expense Item) 626.93
- CON-Z3-FS-02-CW-0030: Expenses: (New Expense Item) 940.39

| ID | WBS | Activity | Type | Duration | Start | Finish | Predecessors | Total float | Free float | Resources | Cost | RPI_P2 - BOQ ITEMS | RPI_P2 - CONSTRUCTION | RPI_P2 - PHASE | RPI_P2 - ZONES | RPI_P2 - AREAS | RPI_P2 - BUILDINGS |
| --- | --- | --- | --- | --- | --- | --- | --- | --- | --- | --- | --- | --- | --- | --- | --- | --- | --- |
|  | 2 | **Architectural & Finishes** |  |  | 2017-03-18 | 2017-05-09 |  |  |  |  |  |  |  |  |  |  |  |
| CON-Z3-FS-02-AR-0010 |  | Plastering Work Internal and External |  | 10d | 2017-03-18 | 2017-03-29 | CON-Z3-FS-02-CW-0030 | 95.8d | 0d | Concrete Mason [78 h]; Common Labor / Helper [26 h]; Scaffolder [26 h]; Finishing Work Crew [52 h] | 940.39 | 1.3.8.40 | CONS | CONS | ZONE-3 | REALM | Fitness S-2 |
| CON-Z3-FS-02-AR-0020 |  | Installation of Concrete Topping and Floor Finishes |  | 10d | 2017-03-29 | 2017-04-10 | CON-Z3-FS-02-AR-0010 | 142.8d | 0d | Common Labor / Helper [52 h]; Finishing Work Crew [52 h] | 1,253.85 | 1.3.8.40 | CONS | CONS | ZONE-3 | REALM | Fitness S-2 |
| CON-Z3-FS-02-AR-0030 |  | Installation of Wooden Roof Trellis and other Wood Works |  | 10d | 2017-04-10 | 2017-04-22 | CON-Z3-FS-02-AR-0020 | 142.8d | 0d | Shuttering Carpenter [52 h]; Common Labor / Helper [78 h]; Scaffolder [52 h]; Wood Works Crew [52 h] | 2,507.71 | 1.3.8.40 | CONS | CONS | ZONE-3 | REALM | Fitness S-2 |
| CON-Z3-FS-02-AR-0040 |  | Painting Work Internal and External |  | 15d | 2017-04-22 | 2017-05-09 | CON-Z3-FS-02-ME-0010 FF+5d, CON-Z3-FS-02-AR-0030 | 142.8d | 47d | Common Labor / Helper [26 h]; Scaffolder [52 h]; Painter [78 h] | 1,567.32 | 1.3.8.40 | CONS | CONS | ZONE-3 | REALM | Fitness S-2 |
|  | 3 | **Mechanical Works** |  |  | 2017-03-29 | 2017-05-03 |  |  |  |  |  |  |  |  |  |  |  |
| CON-Z3-FS-02-ME-0010 |  | Installation of Potable Water Supply System |  | 10d | 2017-03-29 | 2017-04-10 | CON-Z3-FS-02-AR-0010 | 95.8d | 0d | Plumber [78 h]; Common Labor / Helper [52 h] | 3,526.46 | 1.3.8.40 | CONS | CONS | ZONE-3 | REALM | Fitness S-2 |
| CON-Z3-FS-02-ME-0020 |  | Installation of Free Standing Sink with drain |  | 5d | 2017-04-10 | 2017-04-16 | CON-Z3-FS-02-ME-0010 | 135.8d | 0d | Plumber [26 h]; Common Labor / Helper [52 h] | 1,567.32 | 1.3.8.40 | CONS | CONS | ZONE-3 | REALM | Fitness S-2 |
| CON-Z3-FS-02-ME-0050 |  | Instalaltion of Tie in Connection for Water Supply system |  | 10d | 2017-04-10 | 2017-04-22 | CON-Z3-FS-02-ME-0010 | 145.8d | 0d | Plumber [52 h]; Common Labor / Helper [52 h] | 783.66 | 1.3.8.40 | CONS | CONS | ZONE-3 | REALM | Fitness S-2 |
| CON-Z3-FS-02-ME-0030 |  | Installation of Drinking Fountain and BBQ Grill |  | 10d | 2017-04-16 | 2017-04-27 | CON-Z3-FS-02-ME-0020 | 135.8d | 0d | Plumber [26 h]; Common Labor / Helper [52 h] | 1,175.49 | 1.3.8.40 | CONS | CONS | ZONE-3 | REALM | Fitness S-2 |
| CON-Z3-FS-02-ME-0040 |  | Installation of Fire Extinguisher |  | 5d | 2017-04-27 | 2017-05-03 | CON-Z3-FS-02-ME-0030 | 135.8d | 0d | Common Labor / Helper [52 h] | 783.66 | 1.3.8.40 | CONS | CONS | ZONE-3 | REALM | Fitness S-2 |
|  | 4 | **Electrical Works** |  |  | 2017-04-10 | 2017-06-14 |  |  |  |  |  |  |  |  |  |  |  |
| CON-Z3-FS-02-EW-0010 |  | Instalaltion of Conduits |  | 10d | 2017-04-10 | 2017-04-22 | CON-Z3-FS-02-ME-0010 | 95.8d | 0d | Electrician [78 h]; LC Crew [52 h] | 1,175.49 | 1.3.8.40 | CONS | CONS | ZONE-3 | REALM | Fitness S-2 |
| CON-Z3-FS-02-EW-0020 |  | Installation of Cables |  | 10d | 2017-04-22 | 2017-05-03 | CON-Z3-FS-02-EW-0010 | 95.8d | 0d | Electrician [78 h]; LC Crew [52 h] | 1,959.15 | 1.3.8.40 | CONS | CONS | ZONE-3 | REALM | Fitness S-2 |
| CON-Z3-FS-02-EW-0030 |  | Installation of Junction Boxes |  | 8d | 2017-05-03 | 2017-05-13 | CON-Z3-FS-02-EW-0020 | 95.8d | 0d | Electrician [78 h]; LC Crew [52 h] | 783.66 | 1.3.8.40 | CONS | CONS | ZONE-3 | REALM | Fitness S-2 |
| CON-Z3-FS-02-EW-0040 |  | Installation of receptacle outlets and wiring devices |  | 12d | 2017-05-13 | 2017-05-27 | CON-Z3-FS-02-EW-0030 | 95.8d | 0d | Electrician [78 h]; LC Crew [52 h] | 2,350.98 | 1.3.8.40 | CONS | CONS | ZONE-3 | REALM | Fitness S-2 |
| CON-Z3-FS-02-EW-0050 |  | Installation of Internal and External Lighting Fixures |  | 16d | 2017-05-27 | 2017-06-14 | CON-Z3-FS-02-EW-0040 | 95.8d | 0d | Electrician [78 h]; LC Crew [52 h] | 1,567.32 | 1.3.8.40 | CONS | CONS | ZONE-3 | REALM | Fitness S-2 |
|  | 5 | **External Works** |  |  | 2017-05-27 | 2017-06-24 |  |  |  |  |  |  |  |  |  |  |  |
| CON-Z3-FS-02-EXT-010 |  | Installation of Fitness and Playground Equipments |  | 8d | 2017-05-27 | 2017-06-05 | CON-Z3-FS-02-EW-0050 SS | 119.8d | 24d | Common Labor / Helper [78 h] | 2,507.71 | 1.3.8.40 | CONS | CONS | ZONE-3 | REALM | Fitness S-2 |
| CON-Z3-FS-02-EXT-020 |  | Installation of Building Signage |  | 8d | 2017-06-14 | 2017-06-24 | CON-Z3-FS-02-EW-0050 | 103.8d | 8d | Shuttering Carpenter [26 h]; Common Labor / Helper [52 h] | 626.93 | 1.3.8.40 | CONS | CONS | ZONE-3 | REALM | Fitness S-2 |
|  | 6 | **Testing and Precommissioning** |  |  | 2017-04-22 | 2017-07-08 |  |  |  |  |  |  |  |  |  |  |  |
| CON-Z3-FS-02-TC-0010 |  | Testing and Precommissioning of Plumbing Work |  | 12d | 2017-04-22 | 2017-05-06 | CON-Z3-FS-02-ME-0050, CON-Z3-FS-02-ME-0010 | 145.8d | 50d | Plumber [78 h]; Common Labor / Helper [52 h] | 2,350.98 | 1.3.8.40 | CONS | CONS | ZONE-3 | REALM | Fitness S-2 |
| CON-Z3-FS-02-TC-0020 |  | Testing and Precommissioning of Mechanical Work |  | 12d | 2017-05-03 | 2017-05-17 | CON-Z3-FS-02-ME-0040 | 135.8d | 40d | Mechanical Technician [78 h]; Common Labor / Helper [26 h]; HVAC Crew [26 h] | 940.39 | 1.3.8.40 | CONS | CONS | ZONE-3 | REALM | Fitness S-2 |
| CON-Z3-FS-02-TC-0030 |  | Testing and Precommissioning of Electrical Work |  | 16d | 2017-06-14 | 2017-07-08 | CON-Z3-FS-02-EW-0050 | 95.8d | 0d | Electrician [78 h]; Common Labor / Helper [26 h] | 1,410.59 | 1.3.8.40 | CONS | CONS | ZONE-3 | REALM | Fitness S-2 |
| CON-Z3-FS-02-TC-0040 |  | Finish of Fitness Shelter # 02 | milestone | 0d | 2017-07-08 | 2017-07-08 | CON-Z3-FS-02-EXT-020, CON-Z3-FS-02-EXT-010, CON-Z3-FS-02-TC-0010, CON-Z3-FS-02-AR-0040, CON-Z3-FS-02-TC-0030, CON-Z3-FS-02-TC-0020 | 95.8d | 95.6d |  |  | 1.3.8.40 | CONS | CONS | ZONE-3 | REALM | Fitness S-2 |

Notes:
- CON-Z3-FS-02-AR-0010: Expenses: (New Expense Item) 940.39
- CON-Z3-FS-02-AR-0020: Expenses: (New Expense Item) 1253.85
- CON-Z3-FS-02-AR-0030: Expenses: (New Expense Item) 2507.71
- CON-Z3-FS-02-AR-0040: Expenses: (New Expense Item) 1567.32
- CON-Z3-FS-02-ME-0010: Expenses: (New Expense Item) 3526.46
- CON-Z3-FS-02-ME-0020: Expenses: (New Expense Item) 1567.32
- CON-Z3-FS-02-ME-0050: Expenses: (New Expense Item) 783.66
- CON-Z3-FS-02-ME-0030: Expenses: (New Expense Item) 1175.49
- CON-Z3-FS-02-ME-0040: Expenses: (New Expense Item) 783.66
- CON-Z3-FS-02-EW-0010: Expenses: (New Expense Item) 1175.49
- CON-Z3-FS-02-EW-0020: Expenses: (New Expense Item) 1959.15
- CON-Z3-FS-02-EW-0030: Expenses: (New Expense Item) 783.66
- CON-Z3-FS-02-EW-0040: Expenses: (New Expense Item) 2350.98
- CON-Z3-FS-02-EW-0050: Expenses: (New Expense Item) 1567.32
- CON-Z3-FS-02-EXT-010: Expenses: (New Expense Item) 2507.71
- CON-Z3-FS-02-EXT-020: Expenses: (New Expense Item) 626.93
- CON-Z3-FS-02-TC-0010: Expenses: (New Expense Item) 2350.98
- CON-Z3-FS-02-TC-0020: Expenses: (New Expense Item) 940.39
- CON-Z3-FS-02-TC-0030: Expenses: (New Expense Item) 1410.59

| ID | WBS | Activity | Type | Duration | Start | Finish | Predecessors | Total float | Free float | Resources | Cost | RPI_P2 - BOQ ITEMS | RPI_P2 - CONSTRUCTION | RPI_P2 - PHASE | RPI_P2 - ZONES | RPI_P2 - AREAS | RPI_P2 - BUILDINGS |
| --- | --- | --- | --- | --- | --- | --- | --- | --- | --- | --- | --- | --- | --- | --- | --- | --- | --- |
|  | 2 | **Fitness Shelter # 03** |  |  | 2017-03-06 | 2017-07-25 |  |  |  |  |  |  |  |  |  |  |  |
|  | 1 | **Civil / Structural Works** |  |  | 2017-03-06 | 2017-04-04 |  |  |  |  |  |  |  |  |  |  |  |
| CON-Z3-FS-03-CW-0010 |  | Start of Fitness Shelter # 03 | milestone | 0d | 2017-03-06 | 2017-03-06 | CON-Z3-FS-02-CW-0010 FS+15d | 20.8d | 0d |  |  | 1.3.8.40 | CONS | CONS | ZONE-3 | REALM | Fitness S-3 |
| CON-Z3-FS-03-CW-0020 |  | General Backfilling |  | 10d | 2017-03-06 | 2017-03-18 | CON-Z3-FS-03-CW-0010 | 80.8d | 0d | Common Labor / Helper [78 h]; Operator - Loader [26 h]; Driver - Dump Truck [26 h]; Operator - Bobcat [26 h]; Operator - Roller-Compactor (2~10 Ton) [26 h]; Operator - Roller (25 Ton) [26 h]; Driver - Water Tanker [26 h]; Loader [28 h]; Dump Truck [28 h]; Bobcat [28 h]; Roller-Compactor (2~10 Ton) [28 h]; Roller-Compactor (25 Ton) [28 h]; Water Tanker [28 h] | 626.93 | 1.3.8.40 | CONS | CONS | ZONE-3 | REALM | Fitness S-3 |
| CON-Z3-FS-03-CW-0030 |  | Installation of Slab on Garde |  | 15d | 2017-03-18 | 2017-04-04 | CON-Z3-FS-03-CW-0020 | 80.8d | 0d | Steel Fixer [52 h]; Shuttering Carpenter [78 h]; Concrete Mason [78 h]; Common Labor / Helper [78 h] | 940.39 | 1.3.8.40 | CONS | CONS | ZONE-3 | REALM | Fitness S-3 |
|  | 2 | **Architectural & Finishes** |  |  | 2017-04-04 | 2017-05-27 |  |  |  |  |  |  |  |  |  |  |  |
| CON-Z3-FS-03-AR-0010 |  | Plastering Work Internal and External |  | 10d | 2017-04-04 | 2017-04-16 | CON-Z3-FS-03-CW-0030 | 80.8d | 0d | Common Labor / Helper [26 h]; Scaffolder [26 h]; Finishing Work Crew [52 h]; Concrete Mason [78 h] | 940.39 | 1.3.8.40 | CONS | CONS | ZONE-3 | REALM | Fitness S-3 |
| CON-Z3-FS-03-AR-0020 |  | Installation of Concrete Topping and Floor Finishes |  | 10d | 2017-04-16 | 2017-04-27 | CON-Z3-FS-03-AR-0010 | 127.8d | 0d | Common Labor / Helper [52 h]; Finishing Work Crew [52 h] | 1,253.85 | 1.3.8.40 | CONS | CONS | ZONE-3 | REALM | Fitness S-3 |
| CON-Z3-FS-03-AR-0030 |  | Installation of Wooden Roof Trellis and other Wood Works |  | 10d | 2017-04-27 | 2017-05-09 | CON-Z3-FS-03-AR-0020 | 127.8d | 0d | Shuttering Carpenter [52 h]; Common Labor / Helper [78 h]; Scaffolder [52 h]; Wood Works Crew [52 h] | 2,507.71 | 1.3.8.40 | CONS | CONS | ZONE-3 | REALM | Fitness S-3 |
| CON-Z3-FS-03-AR-0040 |  | Painting Work Internal and External |  | 15d | 2017-05-09 | 2017-05-27 | CON-Z3-FS-03-AR-0030, CON-Z3-FS-03-ME-0010 FF+5d | 127.8d | 47d | Common Labor / Helper [26 h]; Scaffolder [52 h]; Painter [78 h] | 1,567.32 | 1.3.8.40 | CONS | CONS | ZONE-3 | REALM | Fitness S-3 |
|  | 3 | **Mechanical Works** |  |  | 2017-04-16 | 2017-06-01 |  |  |  |  |  |  |  |  |  |  |  |
| CON-Z3-FS-03-ME-0010 |  | Installation of Potable Water Supply System |  | 10d | 2017-04-16 | 2017-04-27 | CON-Z3-FS-03-AR-0010 | 80.8d | 0d | Plumber [78 h]; Common Labor / Helper [52 h] | 3,526.46 | 1.3.8.40 | CONS | CONS | ZONE-3 | REALM | Fitness S-3 |
| CON-Z3-FS-03-ME-0020 |  | Installation of Free Standing Sink with drain |  | 5d | 2017-04-27 | 2017-05-03 | CON-Z3-FS-03-ME-0010 | 110.8d | 0d | Plumber [26 h]; Common Labor / Helper [52 h] | 1,567.32 | 1.3.8.40 | CONS | CONS | ZONE-3 | REALM | Fitness S-3 |
| CON-Z3-FS-03-ME-0030 |  | Installation of Drinking Fountain and BBQ Grill |  | 10d | 2017-05-03 | 2017-05-15 | CON-Z3-FS-03-ME-0020 | 110.8d | 0d | Plumber [26 h]; Common Labor / Helper [52 h] | 1,175.49 | 1.3.8.40 | CONS | CONS | ZONE-3 | REALM | Fitness S-3 |
| CON-Z3-FS-03-ME-0040 |  | Installation of Fire Extinguisher |  | 5d | 2017-05-15 | 2017-05-21 | CON-Z3-FS-03-ME-0030 | 110.8d | 0d | Common Labor / Helper [52 h] | 783.66 | 1.3.8.40 | CONS | CONS | ZONE-3 | REALM | Fitness S-3 |
| CON-Z3-FS-03-ME-0050 |  | Instalaltion of Tie in Connection for Water Supply system |  | 10d | 2017-05-21 | 2017-06-01 | CON-Z3-FS-03-ME-0040, CON-Z3-FS-03-ME-0010 | 110.8d | 0d | Plumber [52 h]; Common Labor / Helper [52 h] | 783.66 | 1.3.8.40 | CONS | CONS | ZONE-3 | REALM | Fitness S-3 |
|  | 4 | **Electrical Works** |  |  | 2017-04-27 | 2017-07-06 |  |  |  |  |  |  |  |  |  |  |  |
| CON-Z3-FS-03-EW-0010 |  | Instalaltion of Conduits |  | 10d | 2017-04-27 | 2017-05-09 | CON-Z3-FS-03-ME-0010 | 80.8d | 0d | Electrician [78 h]; LC Crew [52 h] | 1,175.49 | 1.3.8.40 | CONS | CONS | ZONE-3 | REALM | Fitness S-3 |
| CON-Z3-FS-03-EW-0020 |  | Installation of Cables |  | 10d | 2017-05-09 | 2017-05-21 | CON-Z3-FS-03-EW-0010 | 80.8d | 0d | Electrician [78 h]; LC Crew [52 h] | 1,959.15 | 1.3.8.40 | CONS | CONS | ZONE-3 | REALM | Fitness S-3 |
| CON-Z3-FS-03-EW-0030 |  | Installation of Junction Boxes |  | 8d | 2017-05-21 | 2017-05-30 | CON-Z3-FS-03-EW-0020 | 80.8d | 0d | Electrician [78 h]; LC Crew [52 h] | 783.66 | 1.3.8.40 | CONS | CONS | ZONE-3 | REALM | Fitness S-3 |
| CON-Z3-FS-03-EW-0040 |  | Installation of receptacle outlets and wiring devices |  | 12d | 2017-05-30 | 2017-06-13 | CON-Z3-FS-03-EW-0030 | 80.8d | 0d | Electrician [78 h]; LC Crew [52 h] | 2,350.98 | 1.3.8.40 | CONS | CONS | ZONE-3 | REALM | Fitness S-3 |
| CON-Z3-FS-03-EW-0050 |  | Installation of Internal and External Lighting Fixures |  | 16d | 2017-06-13 | 2017-07-06 | CON-Z3-FS-03-EW-0040 | 80.8d | 0d | Electrician [78 h]; LC Crew [52 h] | 1,567.32 | 1.3.8.40 | CONS | CONS | ZONE-3 | REALM | Fitness S-3 |
|  | 5 | **External Works** |  |  | 2017-06-13 | 2017-07-16 |  |  |  |  |  |  |  |  |  |  |  |
| CON-Z3-FS-03-EXT-010 |  | Installation of Fitness and Playground Equipments |  | 8d | 2017-06-13 | 2017-06-22 | CON-Z3-FS-03-EW-0050 SS | 96.8d | 8d | Common Labor / Helper [78 h] | 2,507.71 | 1.3.8.40 | CONS | CONS | ZONE-3 | REALM | Fitness S-3 |
| CON-Z3-FS-03-EXT-020 |  | Installation of Building Signage |  | 8d | 2017-07-06 | 2017-07-16 | CON-Z3-FS-03-EXT-010, CON-Z3-FS-03-EW-0050 | 88.8d | 8d | Shuttering Carpenter [26 h]; Common Labor / Helper [52 h] | 626.93 | 1.3.8.40 | CONS | CONS | ZONE-3 | REALM | Fitness S-3 |

Notes:
- CON-Z3-FS-03-CW-0020: Expenses: (New Expense Item) 626.93
- CON-Z3-FS-03-CW-0030: Expenses: (New Expense Item) 940.39
- CON-Z3-FS-03-AR-0010: Expenses: (New Expense Item) 940.39
- CON-Z3-FS-03-AR-0020: Expenses: (New Expense Item) 1253.85
- CON-Z3-FS-03-AR-0030: Expenses: (New Expense Item) 2507.71
- CON-Z3-FS-03-AR-0040: Expenses: (New Expense Item) 1567.32
- CON-Z3-FS-03-ME-0010: Expenses: (New Expense Item) 3526.46
- CON-Z3-FS-03-ME-0020: Expenses: (New Expense Item) 1567.32
- CON-Z3-FS-03-ME-0030: Expenses: (New Expense Item) 1175.49
- CON-Z3-FS-03-ME-0040: Expenses: (New Expense Item) 783.66
- CON-Z3-FS-03-ME-0050: Expenses: (New Expense Item) 783.66
- CON-Z3-FS-03-EW-0010: Expenses: (New Expense Item) 1175.49
- CON-Z3-FS-03-EW-0020: Expenses: (New Expense Item) 1959.15
- CON-Z3-FS-03-EW-0030: Expenses: (New Expense Item) 783.66
- CON-Z3-FS-03-EW-0040: Expenses: (New Expense Item) 2350.98
- CON-Z3-FS-03-EW-0050: Expenses: (New Expense Item) 1567.32
- CON-Z3-FS-03-EXT-010: Expenses: (New Expense Item) 2507.71
- CON-Z3-FS-03-EXT-020: Expenses: (New Expense Item) 626.93

| ID | WBS | Activity | Type | Duration | Start | Finish | Predecessors | Total float | Free float | Resources | Cost | RPI_P2 - BOQ ITEMS | RPI_P2 - CONSTRUCTION | RPI_P2 - PHASE | RPI_P2 - ZONES | RPI_P2 - AREAS | RPI_P2 - BUILDINGS |
| --- | --- | --- | --- | --- | --- | --- | --- | --- | --- | --- | --- | --- | --- | --- | --- | --- | --- |
|  | 6 | **Testing and Precommissioning** |  |  | 2017-05-21 | 2017-07-25 |  |  |  |  |  |  |  |  |  |  |  |
| CON-Z3-FS-03-TC-0020 |  | Testing and Precommissioning of Mechanical Work |  | 12d | 2017-05-21 | 2017-06-04 | CON-Z3-FS-03-ME-0040 | 120.8d | 40d | Mechanical Technician [78 h]; Common Labor / Helper [26 h]; HVAC Crew [26 h] | 940.39 | 1.3.8.40 | CONS | CONS | ZONE-3 | REALM | Fitness S-3 |
| CON-Z3-FS-03-TC-0010 |  | Testing and Precommissioning of Plumbing Work |  | 12d | 2017-06-01 | 2017-06-15 | CON-Z3-FS-03-ME-0010, CON-Z3-FS-03-ME-0050 | 110.8d | 30d | Plumber [78 h]; Common Labor / Helper [52 h] | 2,350.98 | 1.3.8.40 | CONS | CONS | ZONE-3 | REALM | Fitness S-3 |
| CON-Z3-FS-03-TC-0030 |  | Testing and Precommissioning of Electrical Work |  | 16d | 2017-07-06 | 2017-07-25 | CON-Z3-FS-03-EW-0050 | 80.8d | 0d | Electrician [78 h]; Common Labor / Helper [26 h] | 1,410.59 | 1.3.8.40 | CONS | CONS | ZONE-3 | REALM | Fitness S-3 |
| CON-Z3-FS-03-TC-0040 |  | Finish of Fitness Shelter # 03 | milestone | 0d | 2017-07-25 | 2017-07-25 | CON-Z3-FS-03-TC-0030, CON-Z3-FS-03-EXT-020, CON-Z3-FS-03-AR-0040, CON-Z3-FS-03-TC-0010, CON-Z3-FS-03-TC-0020 | 80.8d | 80.6d |  |  | 1.3.8.40 | CONS | CONS | ZONE-3 | REALM | Fitness S-3 |
|  | 3 | **Fitness Shelter # 04** |  |  | 2017-03-23 | 2017-08-12 |  |  |  |  |  |  |  |  |  |  |  |
|  | 1 | **Civil / Structural Works** |  |  | 2017-03-23 | 2017-04-22 |  |  |  |  |  |  |  |  |  |  |  |
| CON-Z3-FS-04-CW-0010 |  | Start of Fitness Shelter # 04 | milestone | 0d | 2017-03-23 | 2017-03-23 | CON-Z3-FS-03-CW-0010 FS+15d | 20.8d | 0d |  |  | 1.3.8.40 | CONS | CONS | ZONE-3 | REALM | Fitness S-4 |
| CON-Z3-FS-04-CW-0020 |  | General Backfilling |  | 10d | 2017-03-23 | 2017-04-04 | CON-Z3-FS-04-CW-0010 | 65.8d | 0d | Common Labor / Helper [78 h]; Operator - Loader [26 h]; Driver - Dump Truck [26 h]; Operator - Bobcat [26 h]; Operator - Roller-Compactor (2~10 Ton) [26 h]; Operator - Roller (25 Ton) [26 h]; Driver - Water Tanker [26 h]; Loader [28 h]; Dump Truck [28 h]; Bobcat [28 h]; Roller-Compactor (2~10 Ton) [28 h]; Roller-Compactor (25 Ton) [28 h]; Water Tanker [28 h] | 626.93 | 1.3.8.40 | CONS | CONS | ZONE-3 | REALM | Fitness S-4 |
| CON-Z3-FS-04-CW-0030 |  | Installation of Slab on Garde |  | 15d | 2017-04-04 | 2017-04-22 | CON-Z3-FS-04-CW-0020 | 65.8d | 0d | Steel Fixer [52 h]; Shuttering Carpenter [78 h]; Concrete Mason [78 h]; Common Labor / Helper [78 h] | 940.39 | 1.3.8.40 | CONS | CONS | ZONE-3 | REALM | Fitness S-4 |
|  | 2 | **Architectural & Finishes** |  |  | 2017-04-22 | 2017-06-13 |  |  |  |  |  |  |  |  |  |  |  |
| CON-Z3-FS-04-AR-0010 |  | Plastering Work Internal and External |  | 10d | 2017-04-22 | 2017-05-03 | CON-Z3-FS-04-CW-0030 | 65.8d | 0d | Concrete Mason [78 h]; Common Labor / Helper [26 h]; Scaffolder [26 h]; Finishing Work Crew [52 h] | 940.39 | 1.3.8.40 | CONS | CONS | ZONE-3 | REALM | Fitness S-4 |
| CON-Z3-FS-04-AR-0020 |  | Installation of Concrete Topping and Floor Finishes |  | 10d | 2017-05-03 | 2017-05-15 | CON-Z3-FS-04-AR-0010 | 112.8d | 0d | Common Labor / Helper [52 h]; Finishing Work Crew [52 h] | 1,253.85 | 1.3.8.40 | CONS | CONS | ZONE-3 | REALM | Fitness S-4 |
| CON-Z3-FS-04-AR-0030 |  | Installation of Wooden Roof Trellis and other Wood Works |  | 10d | 2017-05-15 | 2017-05-27 | CON-Z3-FS-04-AR-0020 | 112.8d | 0d | Shuttering Carpenter [52 h]; Common Labor / Helper [78 h]; Scaffolder [52 h]; Wood Works Crew [52 h] | 2,507.71 | 1.3.8.40 | CONS | CONS | ZONE-3 | REALM | Fitness S-4 |
| CON-Z3-FS-04-AR-0040 |  | Painting Work Internal and External |  | 15d | 2017-05-27 | 2017-06-13 | CON-Z3-FS-04-AR-0030, CON-Z3-FS-04-ME-0010 FF+5d | 112.8d | 47d | Common Labor / Helper [26 h]; Scaffolder [52 h]; Painter [78 h] | 1,567.32 | 1.3.8.40 | CONS | CONS | ZONE-3 | REALM | Fitness S-4 |
|  | 3 | **Mechanical Works** |  |  | 2017-05-03 | 2017-06-19 |  |  |  |  |  |  |  |  |  |  |  |
| CON-Z3-FS-04-ME-0010 |  | Installation of Potable Water Supply System |  | 10d | 2017-05-03 | 2017-05-15 | CON-Z3-FS-04-AR-0010 | 65.8d | 0d | Plumber [78 h]; Common Labor / Helper [52 h] | 3,526.46 | 1.3.8.40 | CONS | CONS | ZONE-3 | REALM | Fitness S-4 |
| CON-Z3-FS-04-ME-0020 |  | Installation of Free Standing Sink with drain |  | 5d | 2017-05-15 | 2017-05-21 | CON-Z3-FS-04-ME-0010 | 95.8d | 0d | Plumber [26 h]; Common Labor / Helper [52 h] | 1,567.32 | 1.3.8.40 | CONS | CONS | ZONE-3 | REALM | Fitness S-4 |
| CON-Z3-FS-04-ME-0040 |  | Installation of Drinking Fountain and BBQ Grill |  | 10d | 2017-05-21 | 2017-06-01 | CON-Z3-FS-04-ME-0020 | 95.8d | 0d | Plumber [26 h]; Common Labor / Helper [52 h] | 783.66 | 1.3.8.40 | CONS | CONS | ZONE-3 | REALM | Fitness S-4 |
| CON-Z3-FS-04-ME-0050 |  | Installation of Fire Extinguisher |  | 5d | 2017-06-01 | 2017-06-07 | CON-Z3-FS-04-ME-0040 | 95.8d | 0d | Common Labor / Helper [52 h] | 783.66 | 1.3.8.40 | CONS | CONS | ZONE-3 | REALM | Fitness S-4 |
| CON-Z3-FS-04-ME-0030 |  | Instalaltion of Tie in Connection for Water Supply system |  | 10d | 2017-06-07 | 2017-06-19 | CON-Z3-FS-04-ME-0010, CON-Z3-FS-04-ME-0050 | 95.8d | 0d | Plumber [52 h]; Common Labor / Helper [52 h] | 1,175.49 | 1.3.8.40 | CONS | CONS | ZONE-3 | REALM | Fitness S-4 |
|  | 4 | **Electrical Works** |  |  | 2017-05-15 | 2017-07-24 |  |  |  |  |  |  |  |  |  |  |  |
| CON-Z3-FS-04-EW-0010 |  | Instalaltion of Conduits |  | 10d | 2017-05-15 | 2017-05-27 | CON-Z3-FS-04-ME-0010 | 65.8d | 0d | Electrician [78 h]; LC Crew [52 h] | 1,175.49 | 1.3.8.40 | CONS | CONS | ZONE-3 | REALM | Fitness S-4 |
| CON-Z3-FS-04-EW-0020 |  | Installation of Cables |  | 10d | 2017-05-27 | 2017-06-07 | CON-Z3-FS-04-EW-0010 | 65.8d | 0d | Electrician [78 h]; LC Crew [52 h] | 1,959.15 | 1.3.8.40 | CONS | CONS | ZONE-3 | REALM | Fitness S-4 |
| CON-Z3-FS-04-EW-0030 |  | Installation of Junction Boxes |  | 8d | 2017-06-07 | 2017-06-17 | CON-Z3-FS-04-EW-0020 | 65.8d | 0d | Electrician [78 h]; LC Crew [52 h] | 783.66 | 1.3.8.40 | CONS | CONS | ZONE-3 | REALM | Fitness S-4 |
| CON-Z3-FS-04-EW-0040 |  | Installation of receptacle outlets and wiring devices |  | 12d | 2017-06-17 | 2017-07-05 | CON-Z3-FS-04-EW-0030 | 65.8d | 0d | Electrician [78 h]; LC Crew [52 h] | 2,350.98 | 1.3.8.40 | CONS | CONS | ZONE-3 | REALM | Fitness S-4 |
| CON-Z3-FS-04-EW-0050 |  | Installation of Internal and External Lighting Fixures |  | 16d | 2017-07-05 | 2017-07-24 | CON-Z3-FS-04-EW-0040 | 65.8d | 0d | Electrician [78 h]; LC Crew [52 h] | 1,567.32 | 1.3.8.40 | CONS | CONS | ZONE-3 | REALM | Fitness S-4 |

Notes:
- CON-Z3-FS-03-TC-0020: Expenses: (New Expense Item) 940.39
- CON-Z3-FS-03-TC-0010: Expenses: (New Expense Item) 2350.98
- CON-Z3-FS-03-TC-0030: Expenses: (New Expense Item) 1410.59
- CON-Z3-FS-04-CW-0020: Expenses: (New Expense Item) 626.93
- CON-Z3-FS-04-CW-0030: Expenses: (New Expense Item) 940.39
- CON-Z3-FS-04-AR-0010: Expenses: (New Expense Item) 940.39
- CON-Z3-FS-04-AR-0020: Expenses: (New Expense Item) 1253.85
- CON-Z3-FS-04-AR-0030: Expenses: (New Expense Item) 2507.71
- CON-Z3-FS-04-AR-0040: Expenses: (New Expense Item) 1567.32
- CON-Z3-FS-04-ME-0010: Expenses: (New Expense Item) 3526.46
- CON-Z3-FS-04-ME-0020: Expenses: (New Expense Item) 1567.32
- CON-Z3-FS-04-ME-0040: Expenses: (New Expense Item) 783.66
- CON-Z3-FS-04-ME-0050: Expenses: (New Expense Item) 783.66
- CON-Z3-FS-04-ME-0030: Expenses: (New Expense Item) 1175.49
- CON-Z3-FS-04-EW-0010: Expenses: (New Expense Item) 1175.49
- CON-Z3-FS-04-EW-0020: Expenses: (New Expense Item) 1959.15
- CON-Z3-FS-04-EW-0030: Expenses: (New Expense Item) 783.66
- CON-Z3-FS-04-EW-0040: Expenses: (New Expense Item) 2350.98
- CON-Z3-FS-04-EW-0050: Expenses: (New Expense Item) 1567.32

| ID | WBS | Activity | Type | Duration | Start | Finish | Predecessors | Total float | Free float | Resources | Cost | RPI_P2 - BOQ ITEMS | RPI_P2 - CONSTRUCTION | RPI_P2 - PHASE | RPI_P2 - ZONES | RPI_P2 - AREAS | RPI_P2 - BUILDINGS |
| --- | --- | --- | --- | --- | --- | --- | --- | --- | --- | --- | --- | --- | --- | --- | --- | --- | --- |
|  | 5 | **External Works** |  |  | 2017-07-05 | 2017-08-02 |  |  |  |  |  |  |  |  |  |  |  |
| CON-Z3-FS-04-EXT-010 |  | Installation of Fitness and Playground Equipments |  | 8d | 2017-07-05 | 2017-07-15 | CON-Z3-FS-04-EW-0050 SS | 89.8d | 24d | Common Labor / Helper [78 h] | 2,507.71 | 1.3.8.40 | CONS | CONS | ZONE-3 | REALM | Fitness S-4 |
| CON-Z3-FS-04-EXT-020 |  | Installation of Building Signage |  | 8d | 2017-07-24 | 2017-08-02 | CON-Z3-FS-04-EW-0050 | 73.8d | 8d | Shuttering Carpenter [26 h]; Common Labor / Helper [52 h] | 626.93 | 1.3.8.40 | CONS | CONS | ZONE-3 | REALM | Fitness S-4 |
|  | 6 | **Testing and Precommissioning** |  |  | 2017-06-07 | 2017-08-12 |  |  |  |  |  |  |  |  |  |  |  |
| CON-Z3-FS-04-TC-0020 |  | Testing and Precommissioning of Mechanical Work |  | 12d | 2017-06-07 | 2017-06-21 | CON-Z3-FS-04-ME-0050 | 105.8d | 40d | Mechanical Technician [78 h]; Common Labor / Helper [26 h]; HVAC Crew [26 h] | 940.39 | 1.3.8.40 | CONS | CONS | ZONE-3 | REALM | Fitness S-4 |
| CON-Z3-FS-04-TC-0010 |  | Testing and Precommissioning of Plumbing Work |  | 12d | 2017-06-19 | 2017-07-08 | CON-Z3-FS-04-ME-0010, CON-Z3-FS-04-ME-0030 | 95.8d | 30d | Plumber [78 h]; Common Labor / Helper [52 h] | 2,350.98 | 1.3.8.40 | CONS | CONS | ZONE-3 | REALM | Fitness S-4 |
| CON-Z3-FS-04-TC-0030 |  | Testing and Precommissioning of Electrical Work |  | 16d | 2017-07-24 | 2017-08-12 | CON-Z3-FS-04-EW-0050 | 65.8d | 0d | Electrician [78 h]; Common Labor / Helper [26 h] | 1,410.59 | 1.3.8.40 | CONS | CONS | ZONE-3 | REALM | Fitness S-4 |
| CON-Z3-FS-04-TC-0040 |  | Finish of Fitness Shelter # 04 | milestone | 0d | 2017-08-12 | 2017-08-12 | CON-Z3-FS-04-TC-0020, CON-Z3-FS-04-TC-0010, CON-Z3-FS-04-EXT-020, CON-Z3-FS-04-AR-0040, CON-Z3-FS-04-TC-0030, CON-Z3-FS-04-EXT-010 | 65.8d | 65.6d |  |  | 1.3.8.40 | CONS | CONS | ZONE-3 | REALM | Fitness S-4 |
|  | 4 | **Fitness Shelter # 05** |  |  | 2017-04-10 | 2017-08-29 |  |  |  |  |  |  |  |  |  |  |  |
|  | 1 | **Civil / Structural Works** |  |  | 2017-04-10 | 2017-05-09 |  |  |  |  |  |  |  |  |  |  |  |
| CON-Z3-FS-05-CW-0010 |  | Start of Fitness Shelter # 05 | milestone | 0d | 2017-04-10 | 2017-04-10 | CON-Z3-FS-04-CW-0010 FS+15d | 20.8d | 0d |  |  | 1.3.8.40 | CONS | CONS | ZONE-3 | REALM | Fitness S-5 |
| CON-Z3-FS-05-CW-0020 |  | General Backfilling |  | 10d | 2017-04-10 | 2017-04-22 | CON-Z3-FS-05-CW-0010 | 50.8d | 0d | Common Labor / Helper [78 h]; Operator - Loader [26 h]; Driver - Dump Truck [26 h]; Operator - Bobcat [26 h]; Operator - Roller-Compactor (2~10 Ton) [26 h]; Operator - Roller (25 Ton) [26 h]; Driver - Water Tanker [26 h]; Loader [28 h]; Dump Truck [28 h]; Bobcat [28 h]; Roller-Compactor (25 Ton) [28 h]; Water Tanker [28 h]; Roller-Compactor (2~10 Ton) [28 h] | 626.93 | 1.3.8.40 | CONS | CONS | ZONE-3 | REALM | Fitness S-5 |
| CON-Z3-FS-05-CW-0030 |  | Installation of Slab on Garde |  | 15d | 2017-04-22 | 2017-05-09 | CON-Z3-FS-05-CW-0020 | 50.8d | 0d | Steel Fixer [52 h]; Shuttering Carpenter [78 h]; Concrete Mason [78 h]; Common Labor / Helper [78 h] | 940.39 | 1.3.8.40 | CONS | CONS | ZONE-3 | REALM | Fitness S-5 |
|  | 2 | **Architectural & Finishes** |  |  | 2017-05-09 | 2017-07-05 |  |  |  |  |  |  |  |  |  |  |  |
| CON-Z3-FS-05-AR-0030 |  | Plastering Work Internal and External |  | 10d | 2017-05-09 | 2017-05-21 | CON-Z3-FS-05-CW-0030 | 50.8d | 0d | Concrete Mason [78 h]; Common Labor / Helper [26 h]; Scaffolder [26 h]; Finishing Work Crew [52 h] | 2,507.71 | 1.3.8.40 | CONS | CONS | ZONE-3 | REALM | Fitness S-5 |
| CON-Z3-FS-05-AR-0040 |  | Installation of Concrete Topping and Floor Finishes |  | 10d | 2017-05-21 | 2017-06-01 | CON-Z3-FS-05-AR-0030 | 97.8d | 0d | Common Labor / Helper [52 h]; Finishing Work Crew [52 h] | 1,567.32 | 1.3.8.40 | CONS | CONS | ZONE-3 | REALM | Fitness S-5 |
| CON-Z3-FS-05-AR-0010 |  | Installation of Wooden Roof Trellis and other Wood Works |  | 10d | 2017-06-01 | 2017-06-13 | CON-Z3-FS-05-AR-0040 | 97.8d | 0d | Shuttering Carpenter [52 h]; Common Labor / Helper [78 h]; Scaffolder [52 h]; Wood Works Crew [52 h] | 940.39 | 1.3.8.40 | CONS | CONS | ZONE-3 | REALM | Fitness S-5 |
| CON-Z3-FS-05-AR-0020 |  | Painting Work Internal and External |  | 15d | 2017-06-13 | 2017-07-05 | CON-Z3-FS-05-AR-0010, CON-Z3-FS-05-ME-0010 FF+5d | 97.8d | 47d | Common Labor / Helper [26 h]; Scaffolder [52 h]; Painter [78 h] | 1,253.85 | 1.3.8.40 | CONS | CONS | ZONE-3 | REALM | Fitness S-5 |
|  | 3 | **Mechanical Works** |  |  | 2017-05-21 | 2017-07-11 |  |  |  |  |  |  |  |  |  |  |  |
| CON-Z3-FS-05-ME-0010 |  | Installation of Potable Water Supply System |  | 10d | 2017-05-21 | 2017-06-01 | CON-Z3-FS-05-AR-0030 | 50.8d | 0d | Plumber [78 h]; Common Labor / Helper [52 h] | 3,526.46 | 1.3.8.40 | CONS | CONS | ZONE-3 | REALM | Fitness S-5 |
| CON-Z3-FS-05-ME-0020 |  | Installation of Free Standing Sink with drain |  | 5d | 2017-06-01 | 2017-06-07 | CON-Z3-FS-05-ME-0010 | 80.8d | 0d | Plumber [26 h]; Common Labor / Helper [52 h] | 1,567.32 | 1.3.8.40 | CONS | CONS | ZONE-3 | REALM | Fitness S-5 |
| CON-Z3-FS-05-ME-0040 |  | Installation of Drinking Fountain and BBQ Grill |  | 10d | 2017-06-07 | 2017-06-19 | CON-Z3-FS-05-ME-0020 | 80.8d | 0d | Plumber [26 h]; Common Labor / Helper [52 h] | 783.66 | 1.3.8.40 | CONS | CONS | ZONE-3 | REALM | Fitness S-5 |
| CON-Z3-FS-05-ME-0050 |  | Installation of Fire Extinguisher |  | 5d | 2017-06-19 | 2017-06-25 | CON-Z3-FS-05-ME-0040 | 80.8d | 0d | Common Labor / Helper [52 h] | 783.66 | 1.3.8.40 | CONS | CONS | ZONE-3 | REALM | Fitness S-5 |
| CON-Z3-FS-05-ME-0030 |  | Instalaltion of Tie in Connection for Water Supply system |  | 10d | 2017-06-25 | 2017-07-11 | CON-Z3-FS-05-ME-0050, CON-Z3-FS-05-ME-0010 | 80.8d | 0d | Plumber [52 h]; Common Labor / Helper [52 h] | 1,175.49 | 1.3.8.40 | CONS | CONS | ZONE-3 | REALM | Fitness S-5 |

Notes:
- CON-Z3-FS-04-EXT-010: Expenses: (New Expense Item) 2507.71
- CON-Z3-FS-04-EXT-020: Expenses: (New Expense Item) 626.93
- CON-Z3-FS-04-TC-0020: Expenses: (New Expense Item) 940.39
- CON-Z3-FS-04-TC-0010: Expenses: (New Expense Item) 2350.98
- CON-Z3-FS-04-TC-0030: Expenses: (New Expense Item) 1410.59
- CON-Z3-FS-05-CW-0020: Expenses: (New Expense Item) 626.93
- CON-Z3-FS-05-CW-0030: Expenses: (New Expense Item) 940.39
- CON-Z3-FS-05-AR-0030: Expenses: (New Expense Item) 2507.71
- CON-Z3-FS-05-AR-0040: Expenses: (New Expense Item) 1567.32
- CON-Z3-FS-05-AR-0010: Expenses: (New Expense Item) 940.39
- CON-Z3-FS-05-AR-0020: Expenses: (New Expense Item) 1253.85
- CON-Z3-FS-05-ME-0010: Expenses: (New Expense Item) 3526.46
- CON-Z3-FS-05-ME-0020: Expenses: (New Expense Item) 1567.32
- CON-Z3-FS-05-ME-0040: Expenses: (New Expense Item) 783.66
- CON-Z3-FS-05-ME-0050: Expenses: (New Expense Item) 783.66
- CON-Z3-FS-05-ME-0030: Expenses: (New Expense Item) 1175.49

| ID | WBS | Activity | Type | Duration | Start | Finish | Predecessors | Total float | Free float | Resources | Cost | RPI_P2 - BOQ ITEMS | RPI_P2 - CONSTRUCTION | RPI_P2 - PHASE | RPI_P2 - ZONES | RPI_P2 - AREAS | RPI_P2 - BUILDINGS |
| --- | --- | --- | --- | --- | --- | --- | --- | --- | --- | --- | --- | --- | --- | --- | --- | --- | --- |
|  | 4 | **Electrical Works** |  |  | 2017-06-01 | 2017-08-10 |  |  |  |  |  |  |  |  |  |  |  |
| CON-Z3-FS-05-EW-0010 |  | Instalaltion of Conduits |  | 10d | 2017-06-01 | 2017-06-13 | CON-Z3-FS-05-ME-0010 | 50.8d | 0d | Electrician [78 h]; LC Crew [52 h] | 1,175.49 | 1.3.8.40 | CONS | CONS | ZONE-3 | REALM | Fitness S-5 |
| CON-Z3-FS-05-EW-0020 |  | Installation of Cables |  | 10d | 2017-06-13 | 2017-06-25 | CON-Z3-FS-05-EW-0010 | 50.8d | 0d | Electrician [78 h]; LC Crew [52 h] | 1,959.15 | 1.3.8.40 | CONS | CONS | ZONE-3 | REALM | Fitness S-5 |
| CON-Z3-FS-05-EW-0030 |  | Installation of Junction Boxes |  | 8d | 2017-06-25 | 2017-07-09 | CON-Z3-FS-05-EW-0020 | 50.8d | 0d | Electrician [78 h]; LC Crew [52 h] | 783.66 | 1.3.8.40 | CONS | CONS | ZONE-3 | REALM | Fitness S-5 |
| CON-Z3-FS-05-EW-0040 |  | Installation of receptacle outlets and wiring devices |  | 12d | 2017-07-09 | 2017-07-23 | CON-Z3-FS-05-EW-0030 | 50.8d | 0d | Electrician [78 h]; LC Crew [52 h] | 2,350.98 | 1.3.8.40 | CONS | CONS | ZONE-3 | REALM | Fitness S-5 |
| CON-Z3-FS-05-EW-0050 |  | Installation of Internal and External Lighting Fixures |  | 16d | 2017-07-23 | 2017-08-10 | CON-Z3-FS-05-EW-0040 | 50.8d | 0d | Electrician [78 h]; LC Crew [52 h] | 1,567.32 | 1.3.8.40 | CONS | CONS | ZONE-3 | REALM | Fitness S-5 |
|  | 5 | **External Works** |  |  | 2017-07-23 | 2017-08-20 |  |  |  |  |  |  |  |  |  |  |  |
| CON-Z3-FS-05-EXT-010 |  | Installation of Fitness and Playground Equipments |  | 8d | 2017-07-23 | 2017-08-01 | CON-Z3-FS-05-EW-0050 SS | 74.8d | 24d | Common Labor / Helper [78 h] | 2,507.71 | 1.3.8.40 | CONS | CONS | ZONE-3 | REALM | Fitness S-5 |
| CON-Z3-FS-05-EXT-020 |  | Installation of Building Signage |  | 8d | 2017-08-10 | 2017-08-20 | CON-Z3-FS-05-EW-0050 | 58.8d | 8d | Shuttering Carpenter [26 h]; Common Labor / Helper [52 h] | 626.93 | 1.3.8.40 | CONS | CONS | ZONE-3 | REALM | Fitness S-5 |
|  | 6 | **Testing and Precommissioning** |  |  | 2017-06-25 | 2017-08-29 |  |  |  |  |  |  |  |  |  |  |  |
| CON-Z3-FS-05-TC-0020 |  | Testing and Precommissioning of Mechanical Work |  | 12d | 2017-06-25 | 2017-07-13 | CON-Z3-FS-05-ME-0050 | 90.8d | 40d | Mechanical Technician [78 h]; Common Labor / Helper [26 h]; HVAC Crew [26 h] | 940.39 | 1.3.8.40 | CONS | CONS | ZONE-3 | REALM | Fitness S-5 |
| CON-Z3-FS-05-TC-0010 |  | Testing and Precommissioning of Plumbing Work |  | 12d | 2017-07-11 | 2017-07-25 | CON-Z3-FS-05-ME-0010, CON-Z3-FS-05-ME-0030 | 80.8d | 30d | Plumber [78 h]; Common Labor / Helper [52 h] | 2,350.98 | 1.3.8.40 | CONS | CONS | ZONE-3 | REALM | Fitness S-5 |
| CON-Z3-FS-05-TC-0030 |  | Testing and Precommissioning of Electrical Work |  | 16d | 2017-08-10 | 2017-08-29 | CON-Z3-FS-05-EW-0050 | 50.8d | 0d | Electrician [78 h]; Common Labor / Helper [26 h] | 1,410.59 | 1.3.8.40 | CONS | CONS | ZONE-3 | REALM | Fitness S-5 |
| CON-Z3-FS-05-TC-0040 |  | Finish of Fitness Shelter # 05 | milestone | 0d | 2017-08-29 | 2017-08-29 | CON-Z3-FS-05-EXT-020, CON-Z3-FS-05-EXT-010, CON-Z3-FS-05-AR-0020, CON-Z3-FS-05-TC-0030, CON-Z3-FS-05-TC-0010, CON-Z3-FS-05-TC-0020 | 50.8d | 50.6d |  |  | 1.3.8.40 | CONS | CONS | ZONE-3 | REALM | Fitness S-5 |
|  | 6 | **Fitness Shelter # 06** |  |  | 2017-04-27 | 2017-09-20 |  |  |  |  |  |  |  |  |  |  |  |
|  | 1 | **Civil / Structural Works** |  |  | 2017-04-27 | 2017-05-27 |  |  |  |  |  |  |  |  |  |  |  |
| CON-Z3-FS-06-CW-0010 |  | Start of Fitness Shelter # 06 | milestone | 0d | 2017-04-27 | 2017-04-27 | CON-Z3-FS-05-CW-0010 FS+15d | 20.8d | 0d |  |  | 1.3.8.40 | CONS | CONS | ZONE-3 | REALM | Fitness S-6 |
| CON-Z3-FS-06-CW-0020 |  | General Backfilling |  | 10d | 2017-04-27 | 2017-05-09 | CON-Z3-FS-06-CW-0010 | 35.8d | 0d | Common Labor / Helper [78 h]; Operator - Loader [26 h]; Driver - Dump Truck [26 h]; Operator - Bobcat [26 h]; Operator - Roller-Compactor (2~10 Ton) [26 h]; Operator - Roller (25 Ton) [26 h]; Driver - Water Tanker [26 h]; Loader [28 h]; Dump Truck [28 h]; Bobcat [28 h]; Roller-Compactor (2~10 Ton) [28 h]; Roller-Compactor (25 Ton) [28 h]; Water Tanker [28 h] | 626.93 | 1.3.8.40 | CONS | CONS | ZONE-3 | REALM | Fitness S-6 |
| CON-Z3-FS-06-CW-0030 |  | Installation of Slab on Garde |  | 15d | 2017-05-09 | 2017-05-27 | CON-Z3-FS-06-CW-0020 | 35.8d | 0d | Steel Fixer [52 h]; Shuttering Carpenter [78 h]; Concrete Mason [78 h]; Common Labor / Helper [78 h] | 940.39 | 1.3.8.40 | CONS | CONS | ZONE-3 | REALM | Fitness S-6 |
|  | 2 | **Architectural & Finishes** |  |  | 2017-05-27 | 2017-07-23 |  |  |  |  |  |  |  |  |  |  |  |
| CON-Z3-FS-06-AR-0010 |  | Plastering Work Internal and External |  | 10d | 2017-05-27 | 2017-06-07 | CON-Z3-FS-06-CW-0030 | 35.8d | 0d | Common Labor / Helper [26 h]; Scaffolder [26 h]; Finishing Work Crew [52 h]; Concrete Mason [78 h] | 940.39 | 1.3.8.40 | CONS | CONS | ZONE-3 | REALM | Fitness S-6 |
| CON-Z3-FS-06-AR-0020 |  | Installation of Concrete Topping and Floor Finishes |  | 10d | 2017-06-07 | 2017-06-19 | CON-Z3-FS-06-AR-0010 | 82.8d | 0d | Common Labor / Helper [52 h]; Finishing Work Crew [52 h] | 1,253.85 | 1.3.8.40 | CONS | CONS | ZONE-3 | REALM | Fitness S-6 |
| CON-Z3-FS-06-AR-0030 |  | Installation of Wooden Roof Trellis and other Wood Works |  | 10d | 2017-06-19 | 2017-07-05 | CON-Z3-FS-06-AR-0020 | 82.8d | 0d | Shuttering Carpenter [52 h]; Common Labor / Helper [78 h]; Scaffolder [52 h]; Wood Works Crew [52 h] | 2,507.71 | 1.3.8.40 | CONS | CONS | ZONE-3 | REALM | Fitness S-6 |
| CON-Z3-FS-06-AR-0040 |  | Painting Work Internal and External |  | 15d | 2017-07-05 | 2017-07-23 | CON-Z3-FS-06-AR-0030, CON-Z3-FS-06-ME-0010 FF+5d | 82.8d | 47d | Common Labor / Helper [26 h]; Scaffolder [52 h]; Painter [78 h] | 1,567.32 | 1.3.8.40 | CONS | CONS | ZONE-3 | REALM | Fitness S-6 |

Notes:
- CON-Z3-FS-05-EW-0010: Expenses: (New Expense Item) 1175.49
- CON-Z3-FS-05-EW-0020: Expenses: (New Expense Item) 1959.15
- CON-Z3-FS-05-EW-0030: Expenses: (New Expense Item) 783.66
- CON-Z3-FS-05-EW-0040: Expenses: (New Expense Item) 2350.98
- CON-Z3-FS-05-EW-0050: Expenses: (New Expense Item) 1567.32
- CON-Z3-FS-05-EXT-010: Expenses: (New Expense Item) 2507.71
- CON-Z3-FS-05-EXT-020: Expenses: (New Expense Item) 626.93
- CON-Z3-FS-05-TC-0020: Expenses: (New Expense Item) 940.39
- CON-Z3-FS-05-TC-0010: Expenses: (New Expense Item) 2350.98
- CON-Z3-FS-05-TC-0030: Expenses: (New Expense Item) 1410.59
- CON-Z3-FS-06-CW-0020: Expenses: (New Expense Item) 626.93
- CON-Z3-FS-06-CW-0030: Expenses: (New Expense Item) 940.39
- CON-Z3-FS-06-AR-0010: Expenses: (New Expense Item) 940.39
- CON-Z3-FS-06-AR-0020: Expenses: (New Expense Item) 1253.85
- CON-Z3-FS-06-AR-0030: Expenses: (New Expense Item) 2507.71
- CON-Z3-FS-06-AR-0040: Expenses: (New Expense Item) 1567.32

| ID | WBS | Activity | Type | Duration | Start | Finish | Predecessors | Total float | Free float | Resources | Cost | RPI_P2 - BOQ ITEMS | RPI_P2 - CONSTRUCTION | RPI_P2 - PHASE | RPI_P2 - ZONES | RPI_P2 - AREAS | RPI_P2 - BUILDINGS |
| --- | --- | --- | --- | --- | --- | --- | --- | --- | --- | --- | --- | --- | --- | --- | --- | --- | --- |
|  | 3 | **Mechanical Works** |  |  | 2017-06-07 | 2017-07-29 |  |  |  |  |  |  |  |  |  |  |  |
| CON-Z3-FS-06-ME-0010 |  | Installation of Potable Water Supply System |  | 10d | 2017-06-07 | 2017-06-19 | CON-Z3-FS-06-AR-0010 | 35.8d | 0d | Plumber [78 h]; Common Labor / Helper [52 h] | 3,526.46 | 1.3.8.40 | CONS | CONS | ZONE-3 | REALM | Fitness S-6 |
| CON-Z3-FS-06-ME-0020 |  | Installation of Free Standing Sink with drain |  | 5d | 2017-06-19 | 2017-06-25 | CON-Z3-FS-06-ME-0010 | 65.8d | 0d | Plumber [26 h]; Common Labor / Helper [52 h] | 1,567.32 | 1.3.8.40 | CONS | CONS | ZONE-3 | REALM | Fitness S-6 |
| CON-Z3-FS-06-ME-0040 |  | Installation of Drinking Fountain and BBQ Grill |  | 10d | 2017-06-25 | 2017-07-11 | CON-Z3-FS-06-ME-0020 | 65.8d | 0d | Plumber [26 h]; Common Labor / Helper [52 h] | 783.66 | 1.3.8.40 | CONS | CONS | ZONE-3 | REALM | Fitness S-6 |
| CON-Z3-FS-06-ME-0050 |  | Installation of Fire Extinguisher |  | 5d | 2017-07-11 | 2017-07-17 | CON-Z3-FS-06-ME-0040 | 65.8d | 0d | Common Labor / Helper [52 h] | 783.66 | 1.3.8.40 | CONS | CONS | ZONE-3 | REALM | Fitness S-6 |
| CON-Z3-FS-06-ME-0030 |  | Instalaltion of Tie in Connection for Water Supply system |  | 10d | 2017-07-17 | 2017-07-29 | CON-Z3-FS-06-ME-0010, CON-Z3-FS-06-ME-0050 | 65.8d | 0d | Plumber [52 h]; Common Labor / Helper [52 h] | 1,175.49 | 1.3.8.40 | CONS | CONS | ZONE-3 | REALM | Fitness S-6 |
|  | 4 | **Electrical Works** |  |  | 2017-06-19 | 2017-08-28 |  |  |  |  |  |  |  |  |  |  |  |
| CON-Z3-FS-06-EW-0010 |  | Instalaltion of Conduits |  | 10d | 2017-06-19 | 2017-07-05 | CON-Z3-FS-06-ME-0010 | 35.8d | 0d | Electrician [78 h]; LC Crew [52 h] | 1,175.49 | 1.3.8.40 | CONS | CONS | ZONE-3 | REALM | Fitness S-6 |
| CON-Z3-FS-06-EW-0020 |  | Installation of Cables |  | 10d | 2017-07-05 | 2017-07-17 | CON-Z3-FS-06-EW-0010 | 35.8d | 0d | Electrician [78 h]; LC Crew [52 h] | 1,959.15 | 1.3.8.40 | CONS | CONS | ZONE-3 | REALM | Fitness S-6 |
| CON-Z3-FS-06-EW-0030 |  | Installation of Junction Boxes |  | 8d | 2017-07-17 | 2017-07-26 | CON-Z3-FS-06-EW-0020 | 35.8d | 0d | Electrician [78 h]; LC Crew [52 h] | 783.66 | 1.3.8.40 | CONS | CONS | ZONE-3 | REALM | Fitness S-6 |
| CON-Z3-FS-06-EW-0040 |  | Installation of receptacle outlets and wiring devices |  | 12d | 2017-07-26 | 2017-08-09 | CON-Z3-FS-06-EW-0030 | 35.8d | 0d | Electrician [78 h]; LC Crew [52 h] | 2,350.98 | 1.3.8.40 | CONS | CONS | ZONE-3 | REALM | Fitness S-6 |
| CON-Z3-FS-06-EW-0050 |  | Installation of Internal and External Lighting Fixures |  | 16d | 2017-08-09 | 2017-08-28 | CON-Z3-FS-06-EW-0040 | 35.8d | 0d | Electrician [78 h]; LC Crew [52 h] | 1,567.32 | 1.3.8.40 | CONS | CONS | ZONE-3 | REALM | Fitness S-6 |
|  | 5 | **External Works** |  |  | 2017-08-09 | 2017-09-11 |  |  |  |  |  |  |  |  |  |  |  |
| CON-Z3-FS-06-EXT-010 |  | Installation of Fitness and Playground Equipments |  | 8d | 2017-08-09 | 2017-08-19 | CON-Z3-FS-06-EW-0050 SS | 59.8d | 24d | Common Labor / Helper [78 h] | 2,507.71 | 1.3.8.40 | CONS | CONS | ZONE-3 | REALM | Fitness S-6 |
| CON-Z3-FS-06-EXT-020 |  | Installation of Building Signage |  | 8d | 2017-08-28 | 2017-09-11 | CON-Z3-FS-06-EW-0050 | 43.8d | 8d | Shuttering Carpenter [26 h]; Common Labor / Helper [52 h] | 626.93 | 1.3.8.40 | CONS | CONS | ZONE-3 | REALM | Fitness S-6 |
|  | 6 | **Testing and Precommissioning** |  |  | 2017-07-17 | 2017-09-20 |  |  |  |  |  |  |  |  |  |  |  |
| CON-Z3-FS-06-TC-0020 |  | Testing and Precommissioning of Mechanical Work |  | 12d | 2017-07-17 | 2017-07-31 | CON-Z3-FS-06-ME-0050 | 75.8d | 40d | Mechanical Technician [78 h]; Common Labor / Helper [26 h]; HVAC Crew [26 h] | 940.39 | 1.3.8.40 | CONS | CONS | ZONE-3 | REALM | Fitness S-6 |
| CON-Z3-FS-06-TC-0010 |  | Testing and Precommissioning of Plumbing Work |  | 12d | 2017-07-29 | 2017-08-12 | CON-Z3-FS-06-ME-0010, CON-Z3-FS-06-ME-0030 | 65.8d | 30d | Plumber [78 h]; Common Labor / Helper [52 h] | 2,350.98 | 1.3.8.40 | CONS | CONS | ZONE-3 | REALM | Fitness S-6 |
| CON-Z3-FS-06-TC-0030 |  | Testing and Precommissioning of Electrical Work |  | 16d | 2017-08-28 | 2017-09-20 | CON-Z3-FS-06-EW-0050 | 35.8d | 0d | Electrician [78 h]; Common Labor / Helper [26 h] | 1,410.59 | 1.3.8.40 | CONS | CONS | ZONE-3 | REALM | Fitness S-6 |
| CON-Z3-FS-06-TC-0040 |  | Finish of Fitness Shelter # 06 | milestone | 0d | 2017-09-20 | 2017-09-20 | CON-Z3-FS-06-TC-0010, CON-Z3-FS-06-EXT-020, CON-Z3-FS-06-TC-0020, CON-Z3-FS-06-TC-0030, CON-Z3-FS-06-AR-0040, CON-Z3-FS-06-EXT-010 | 35.8d | 35.6d |  |  | 1.3.8.40 | CONS | CONS | ZONE-3 | REALM | Fitness S-6 |
|  | 7 | **Fitness Shelter # 07** |  |  | 2017-05-15 | 2017-10-09 |  |  |  |  |  |  |  |  |  |  |  |
|  | 1 | **Civil / Structural Works** |  |  | 2017-05-15 | 2017-06-13 |  |  |  |  |  |  |  |  |  |  |  |
| CON-Z3-FS-07-CW-0010 |  | Start of Fitness Shelter # 07 | milestone | 0d | 2017-05-15 | 2017-05-15 | CON-Z3-FS-06-CW-0010 FS+15d | 20.8d | 0d |  |  | 1.3.8.40 | CONS | CONS | ZONE-3 | REALM | Fitness S-7 |
| CON-Z3-FS-07-CW-0020 |  | General Backfilling |  | 10d | 2017-05-15 | 2017-05-27 | CON-Z3-FS-07-CW-0010 | 20.8d | 0d | Common Labor / Helper [78 h]; Operator - Loader [26 h]; Driver - Dump Truck [26 h]; Operator - Bobcat [26 h]; Operator - Roller-Compactor (2~10 Ton) [26 h]; Operator - Roller (25 Ton) [26 h]; Driver - Water Tanker [26 h]; Loader [28 h]; Dump Truck [28 h]; Bobcat [28 h]; Roller-Compactor (2~10 Ton) [28 h]; Roller-Compactor (25 Ton) [28 h]; Water Tanker [28 h] | 626.93 | 1.3.8.40 | CONS | CONS | ZONE-3 | REALM | Fitness S-7 |
| CON-Z3-FS-07-CW-0030 |  | Installation of Slab on Garde |  | 15d | 2017-05-27 | 2017-06-13 | CON-Z3-FS-07-CW-0020 | 20.8d | 0d | Steel Fixer [52 h]; Shuttering Carpenter [78 h]; Concrete Mason [78 h]; Common Labor / Helper [78 h] | 940.39 | 1.3.8.40 | CONS | CONS | ZONE-3 | REALM | Fitness S-7 |

Notes:
- CON-Z3-FS-06-ME-0010: Expenses: (New Expense Item) 3526.46
- CON-Z3-FS-06-ME-0020: Expenses: (New Expense Item) 1567.32
- CON-Z3-FS-06-ME-0040: Expenses: (New Expense Item) 783.66
- CON-Z3-FS-06-ME-0050: Expenses: (New Expense Item) 783.66
- CON-Z3-FS-06-ME-0030: Expenses: (New Expense Item) 1175.49
- CON-Z3-FS-06-EW-0010: Expenses: (New Expense Item) 1175.49
- CON-Z3-FS-06-EW-0020: Expenses: (New Expense Item) 1959.15
- CON-Z3-FS-06-EW-0030: Expenses: (New Expense Item) 783.66
- CON-Z3-FS-06-EW-0040: Expenses: (New Expense Item) 2350.98
- CON-Z3-FS-06-EW-0050: Expenses: (New Expense Item) 1567.32
- CON-Z3-FS-06-EXT-010: Expenses: (New Expense Item) 2507.71
- CON-Z3-FS-06-EXT-020: Expenses: (New Expense Item) 626.93
- CON-Z3-FS-06-TC-0020: Expenses: (New Expense Item) 940.39
- CON-Z3-FS-06-TC-0010: Expenses: (New Expense Item) 2350.98
- CON-Z3-FS-06-TC-0030: Expenses: (New Expense Item) 1410.59
- CON-Z3-FS-07-CW-0020: Expenses: (New Expense Item) 626.93
- CON-Z3-FS-07-CW-0030: Expenses: (New Expense Item) 940.39

| ID | WBS | Activity | Type | Duration | Start | Finish | Predecessors | Total float | Free float | Resources | Cost | RPI_P2 - BOQ ITEMS | RPI_P2 - CONSTRUCTION | RPI_P2 - PHASE | RPI_P2 - ZONES | RPI_P2 - AREAS | RPI_P2 - BUILDINGS |
| --- | --- | --- | --- | --- | --- | --- | --- | --- | --- | --- | --- | --- | --- | --- | --- | --- | --- |
|  | 2 | **Architectural & Finishes** |  |  | 2017-06-13 | 2017-08-09 |  |  |  |  |  |  |  |  |  |  |  |
| CON-Z3-FS-07-AR-0010 |  | Plastering Work Internal and External |  | 10d | 2017-06-13 | 2017-06-25 | CON-Z3-FS-07-CW-0030 | 20.8d | 0d | Concrete Mason [78 h]; Common Labor / Helper [26 h]; Scaffolder [26 h]; Finishing Work Crew [52 h] | 940.39 | 1.3.8.40 | CONS | CONS | ZONE-3 | REALM | Fitness S-7 |
| CON-Z3-FS-07-AR-0020 |  | Installation of Concrete Topping and Floor Finishes |  | 10d | 2017-06-25 | 2017-07-11 | CON-Z3-FS-07-AR-0010 | 67.8d | 0d | Common Labor / Helper [52 h]; Finishing Work Crew [52 h] | 1,253.85 | 1.3.8.40 | CONS | CONS | ZONE-3 | REALM | Fitness S-7 |
| CON-Z3-FS-07-AR-0030 |  | Installation of Wooden Roof Trellis and other Wood Works |  | 10d | 2017-07-11 | 2017-07-23 | CON-Z3-FS-07-AR-0020 | 67.8d | 0d | Shuttering Carpenter [52 h]; Common Labor / Helper [78 h]; Scaffolder [52 h]; Wood Works Crew [52 h] | 2,507.71 | 1.3.8.40 | CONS | CONS | ZONE-3 | REALM | Fitness S-7 |
| CON-Z3-FS-07-AR-0040 |  | Painting Work Internal and External |  | 15d | 2017-07-23 | 2017-08-09 | CON-Z3-FS-07-AR-0030, CON-Z3-FS-07-ME-0010 FF+5d | 67.8d | 47d | Common Labor / Helper [26 h]; Scaffolder [52 h]; Painter [78 h] | 1,567.32 | 1.3.8.40 | CONS | CONS | ZONE-3 | REALM | Fitness S-7 |
|  | 3 | **Mechanical Works** |  |  | 2017-06-25 | 2017-08-15 |  |  |  |  |  |  |  |  |  |  |  |
| CON-Z3-FS-07-ME-0010 |  | Installation of Potable Water Supply System |  | 10d | 2017-06-25 | 2017-07-11 | CON-Z3-FS-07-AR-0010 | 20.8d | 0d | Common Labor / Helper [52 h]; Plumber [78 h] | 3,526.46 | 1.3.8.40 | CONS | CONS | ZONE-3 | REALM | Fitness S-7 |
| CON-Z3-FS-07-ME-0020 |  | Installation of Free Standing Sink with drain |  | 5d | 2017-07-11 | 2017-07-17 | CON-Z3-FS-07-ME-0010 | 50.8d | 0d | Plumber [26 h]; Common Labor / Helper [52 h] | 1,567.32 | 1.3.8.40 | CONS | CONS | ZONE-3 | REALM | Fitness S-7 |
| CON-Z3-FS-07-ME-0040 |  | Installation of Drinking Fountain and BBQ Grill |  | 10d | 2017-07-17 | 2017-07-29 | CON-Z3-FS-07-ME-0020 | 50.8d | 0d | Plumber [26 h]; Common Labor / Helper [52 h] | 783.66 | 1.3.8.40 | CONS | CONS | ZONE-3 | REALM | Fitness S-7 |
| CON-Z3-FS-07-ME-0050 |  | Installation of Fire Extinguisher |  | 5d | 2017-07-29 | 2017-08-03 | CON-Z3-FS-07-ME-0040 | 50.8d | 0d | Common Labor / Helper [52 h] | 783.66 | 1.3.8.40 | CONS | CONS | ZONE-3 | REALM | Fitness S-7 |
| CON-Z3-FS-07-ME-0030 |  | Instalaltion of Tie in Connection for Water Supply system |  | 10d | 2017-08-03 | 2017-08-15 | CON-Z3-FS-07-ME-0050, CON-Z3-FS-07-ME-0010 | 50.8d | 0d | Plumber [52 h]; Common Labor / Helper [52 h] | 1,175.49 | 1.3.8.40 | CONS | CONS | ZONE-3 | REALM | Fitness S-7 |
|  | 4 | **Electrical Works** |  |  | 2017-07-11 | 2017-09-19 |  |  |  |  |  |  |  |  |  |  |  |
| CON-Z3-FS-07-EW-0010 |  | Instalaltion of Conduits |  | 10d | 2017-07-11 | 2017-07-23 | CON-Z3-FS-07-ME-0010 | 20.8d | 0d | Electrician [78 h]; LC Crew [52 h] | 1,175.49 | 1.3.8.40 | CONS | CONS | ZONE-3 | REALM | Fitness S-7 |
| CON-Z3-FS-07-EW-0020 |  | Installation of Cables |  | 10d | 2017-07-23 | 2017-08-03 | CON-Z3-FS-07-EW-0010 | 20.8d | 0d | Electrician [78 h]; LC Crew [52 h] | 1,959.15 | 1.3.8.40 | CONS | CONS | ZONE-3 | REALM | Fitness S-7 |
| CON-Z3-FS-07-EW-0030 |  | Installation of Junction Boxes |  | 8d | 2017-08-03 | 2017-08-13 | CON-Z3-FS-07-EW-0020 | 20.8d | 0d | Electrician [78 h]; LC Crew [52 h] | 783.66 | 1.3.8.40 | CONS | CONS | ZONE-3 | REALM | Fitness S-7 |
| CON-Z3-FS-07-EW-0040 |  | Installation of receptacle outlets and wiring devices |  | 12d | 2017-08-13 | 2017-08-27 | CON-Z3-FS-07-EW-0030 | 20.8d | 0d | Electrician [78 h]; LC Crew [52 h] | 2,350.98 | 1.3.8.40 | CONS | CONS | ZONE-3 | REALM | Fitness S-7 |
| CON-Z3-FS-07-EW-0050 |  | Installation of Internal and External Lighting Fixures |  | 16d | 2017-08-27 | 2017-09-19 | CON-Z3-FS-07-EW-0040 | 20.8d | 0d | Electrician [78 h]; LC Crew [52 h] | 1,567.32 | 1.3.8.40 | CONS | CONS | ZONE-3 | REALM | Fitness S-7 |
|  | 5 | **External Works** |  |  | 2017-08-27 | 2017-09-30 |  |  |  |  |  |  |  |  |  |  |  |
| CON-Z3-FS-07-EXT-010 |  | Installation of Fitness and Playground Equipments |  | 8d | 2017-08-27 | 2017-09-10 | CON-Z3-FS-07-EW-0050 SS | 44.8d | 24d | Common Labor / Helper [78 h] | 2,507.71 | 1.3.8.40 | CONS | CONS | ZONE-3 | REALM | Fitness S-7 |
| CON-Z3-FS-07-EXT-020 |  | Installation of Building Signage |  | 8d | 2017-09-19 | 2017-09-30 | CON-Z3-FS-07-EW-0050 | 28.8d | 8d | Shuttering Carpenter [26 h]; Common Labor / Helper [52 h] | 626.93 | 1.3.8.40 | CONS | CONS | ZONE-3 | REALM | Fitness S-7 |
|  | 6 | **Testing and Precommissioning** |  |  | 2017-08-03 | 2017-10-09 |  |  |  |  |  |  |  |  |  |  |  |
| CON-Z3-FS-07-TC-0020 |  | Testing and Precommissioning of Mechanical Work |  | 12d | 2017-08-03 | 2017-08-17 | CON-Z3-FS-07-ME-0050 | 60.8d | 40d | Mechanical Technician [78 h]; Common Labor / Helper [26 h]; HVAC Crew [26 h] | 940.39 | 1.3.8.40 | CONS | CONS | ZONE-3 | REALM | Fitness S-7 |
| CON-Z3-FS-07-TC-0010 |  | Testing and Precommissioning of Plumbing Work |  | 12d | 2017-08-15 | 2017-08-29 | CON-Z3-FS-07-ME-0030, CON-Z3-FS-07-ME-0010 | 50.8d | 30d | Plumber [78 h]; Common Labor / Helper [52 h] | 2,350.98 | 1.3.8.40 | CONS | CONS | ZONE-3 | REALM | Fitness S-7 |
| CON-Z3-FS-07-TC-0030 |  | Testing and Precommissioning of Electrical Work |  | 16d | 2017-09-19 | 2017-10-09 | CON-Z3-FS-07-EW-0050 | 20.8d | 0d | Electrician [78 h]; Common Labor / Helper [26 h] | 1,410.59 | 1.3.8.40 | CONS | CONS | ZONE-3 | REALM | Fitness S-7 |
| CON-Z3-FS-07-TC-0040 |  | Finish of Fitness Shelter # 07 | milestone | 0d | 2017-10-09 | 2017-10-09 | CON-Z3-FS-07-TC-0010, CON-Z3-FS-07-AR-0040, CON-Z3-FS-07-TC-0020, CON-Z3-FS-07-TC-0030, CON-Z3-FS-07-EXT-010, CON-Z3-FS-07-EXT-020 | 20.8d | 20.6d |  |  | 1.3.8.40 | CONS | CONS | ZONE-3 | REALM | Fitness S-7 |

Notes:
- CON-Z3-FS-07-AR-0010: Expenses: (New Expense Item) 940.39
- CON-Z3-FS-07-AR-0020: Expenses: (New Expense Item) 1253.85
- CON-Z3-FS-07-AR-0030: Expenses: (New Expense Item) 2507.71
- CON-Z3-FS-07-AR-0040: Expenses: (New Expense Item) 1567.32
- CON-Z3-FS-07-ME-0010: Expenses: (New Expense Item) 3526.46
- CON-Z3-FS-07-ME-0020: Expenses: (New Expense Item) 1567.32
- CON-Z3-FS-07-ME-0040: Expenses: (New Expense Item) 783.66
- CON-Z3-FS-07-ME-0050: Expenses: (New Expense Item) 783.66
- CON-Z3-FS-07-ME-0030: Expenses: (New Expense Item) 1175.49
- CON-Z3-FS-07-EW-0010: Expenses: (New Expense Item) 1175.49
- CON-Z3-FS-07-EW-0020: Expenses: (New Expense Item) 1959.15
- CON-Z3-FS-07-EW-0030: Expenses: (New Expense Item) 783.66
- CON-Z3-FS-07-EW-0040: Expenses: (New Expense Item) 2350.98
- CON-Z3-FS-07-EW-0050: Expenses: (New Expense Item) 1567.32
- CON-Z3-FS-07-EXT-010: Expenses: (New Expense Item) 2507.71
- CON-Z3-FS-07-EXT-020: Expenses: (New Expense Item) 626.93
- CON-Z3-FS-07-TC-0020: Expenses: (New Expense Item) 940.39
- CON-Z3-FS-07-TC-0010: Expenses: (New Expense Item) 2350.98
- CON-Z3-FS-07-TC-0030: Expenses: (New Expense Item) 1410.59

| ID | WBS | Activity | Type | Duration | Start | Finish | Predecessors | Total float | Free float | Resources | Cost | RPI_P2 - BOQ ITEMS | RPI_P2 - CONSTRUCTION | RPI_P2 - PHASE | RPI_P2 - ZONES | RPI_P2 - AREAS | RPI_P2 - BUILDINGS |
| --- | --- | --- | --- | --- | --- | --- | --- | --- | --- | --- | --- | --- | --- | --- | --- | --- | --- |
|  | 5 | **Art Works Shelters (08 No.s)** |  |  | 2017-02-22 | 2017-10-09 |  |  |  |  |  |  |  |  |  |  |  |
|  | 9 | **Art Works Shelter # 01** |  |  | 2017-02-22 | 2017-07-13 |  |  |  |  |  |  |  |  |  |  |  |
|  | 1 | **Civil / Structural Works** |  |  | 2017-02-22 | 2017-03-23 |  |  |  |  |  |  |  |  |  |  |  |
| CON-Z3-AS-01-CW-0010 |  | Start of Art Works Shelter # 01 | milestone | 0d | 2017-02-22 | 2017-02-22 | CON-CON-CON-CON-0010 FS+165d | 20.8d | 0d |  |  | 1.3.8.50 | CONS | CONS | ZONE-3 | REALM | Art S-1 |
| CON-Z3-AS-01-CW-0020 |  | General Backfilling |  | 10d | 2017-02-22 | 2017-03-06 | CON-Z3-AS-01-CW-0010 | 90.8d | 0d | Dump Truck [28 h]; Bobcat [28 h]; Roller-Compactor (2~10 Ton) [28 h]; Roller-Compactor (25 Ton) [28 h]; Water Tanker [28 h]; Common Labor / Helper [78 h]; Operator - Loader [26 h]; Driver - Dump Truck [26 h]; Operator - Bobcat [26 h]; Operator - Roller-Compactor (2~10 Ton) [26 h]; Operator - Roller (25 Ton) [26 h]; Driver - Water Tanker [26 h]; Loader [28 h] | 1,316.55 | 1.3.8.50 | CONS | CONS | ZONE-3 | REALM | Art S-1 |
| CON-Z3-AS-01-CW-0030 |  | Installation of Slab on Garde |  | 15d | 2017-03-06 | 2017-03-23 | CON-Z3-AS-01-CW-0020 | 90.8d | 0d | Steel Fixer [52 h]; Shuttering Carpenter [78 h]; Concrete Mason [78 h]; Common Labor / Helper [78 h] | 1,974.82 | 1.3.8.50 | CONS | CONS | ZONE-3 | REALM | Art S-1 |
|  | 2 | **Architectural & Finishes** |  |  | 2017-03-23 | 2017-05-15 |  |  |  |  |  |  |  |  |  |  |  |
| CON-Z3-AS-01-AR-0010 |  | Plastering Work Internal and External |  | 10d | 2017-03-23 | 2017-04-04 | CON-Z3-AS-01-CW-0030 | 90.8d | 0d | Concrete Mason [78 h]; Common Labor / Helper [26 h]; Scaffolder [26 h]; Finishing Work Crew [52 h] | 822.84 | 1.3.8.50 | CONS | CONS | ZONE-3 | REALM | Art S-1 |
| CON-Z3-AS-01-AR-0020 |  | Installation of Concrete Topping and Floor Finishes |  | 10d | 2017-04-04 | 2017-04-16 | CON-Z3-AS-01-AR-0010 | 137.8d | 0d | Common Labor / Helper [52 h]; Finishing Work Crew [52 h] | 1,097.12 | 1.3.8.50 | CONS | CONS | ZONE-3 | REALM | Art S-1 |
| CON-Z3-AS-01-AR-0030 |  | Installation of Wooden Roof Trellis and other Wood Works |  | 10d | 2017-04-16 | 2017-04-27 | CON-Z3-AS-01-AR-0020 | 137.8d | 0d | Shuttering Carpenter [52 h]; Common Labor / Helper [78 h]; Scaffolder [52 h]; Wood Works Crew [52 h] | 2,194.24 | 1.3.8.50 | CONS | CONS | ZONE-3 | REALM | Art S-1 |
| CON-Z3-AS-01-AR-0040 |  | Painting Work Internal and External |  | 15d | 2017-04-27 | 2017-05-15 | CON-Z3-AS-01-AR-0030, CON-Z3-AS-01-ME-0010 FF+5d | 137.8d | 47d | Common Labor / Helper [26 h]; Scaffolder [52 h]; Painter [78 h] | 1,371.4 | 1.3.8.50 | CONS | CONS | ZONE-3 | REALM | Art S-1 |
|  | 3 | **Mechanical Works** |  |  | 2017-04-04 | 2017-05-21 |  |  |  |  |  |  |  |  |  |  |  |
| CON-Z3-AS-01-ME-0010 |  | Installation of Potable Water Supply System |  | 10d | 2017-04-04 | 2017-04-16 | CON-Z3-AS-01-AR-0010 | 90.8d | 0d | Plumber [78 h]; Common Labor / Helper [52 h] | 4,114.21 | 1.3.8.50 | CONS | CONS | ZONE-3 | REALM | Art S-1 |
| CON-Z3-AS-01-ME-0020 |  | Installation of Free Standing Sink with drain |  | 5d | 2017-04-16 | 2017-04-22 | CON-Z3-AS-01-ME-0010 | 120.8d | 0d | Plumber [26 h]; Common Labor / Helper [52 h] | 1,234.26 | 1.3.8.50 | CONS | CONS | ZONE-3 | REALM | Art S-1 |
| CON-Z3-AS-01-ME-0040 |  | Installation of Drinking Fountain and BBQ Grill |  | 10d | 2017-04-22 | 2017-05-03 | CON-Z3-AS-01-ME-0020 | 120.8d | 0d | Plumber [26 h]; Common Labor / Helper [52 h] | 822.84 | 1.3.8.50 | CONS | CONS | ZONE-3 | REALM | Art S-1 |
| CON-Z3-AS-01-ME-0050 |  | Installation of Fire Extinguisher |  | 5d | 2017-05-03 | 2017-05-09 | CON-Z3-AS-01-ME-0040 | 120.8d | 0d | Common Labor / Helper [52 h] | 822.84 | 1.3.8.50 | CONS | CONS | ZONE-3 | REALM | Art S-1 |
| CON-Z3-AS-01-ME-0030 |  | Instalaltion of Tie in Connection for Water Supply system |  | 10d | 2017-05-09 | 2017-05-21 | CON-Z3-AS-01-ME-0010, CON-Z3-AS-01-ME-0050 | 120.8d | 0d | Plumber [52 h]; Common Labor / Helper [52 h] | 1,234.26 | 1.3.8.50 | CONS | CONS | ZONE-3 | REALM | Art S-1 |
|  | 4 | **Electrical Works** |  |  | 2017-04-16 | 2017-06-20 |  |  |  |  |  |  |  |  |  |  |  |
| CON-Z3-AS-01-EW-0010 |  | Instalaltion of Conduits |  | 10d | 2017-04-16 | 2017-04-27 | CON-Z3-AS-01-ME-0010 | 90.8d | 0d | Electrician [78 h]; LC Crew [52 h] | 548.56 | 1.3.8.50 | CONS | CONS | ZONE-3 | REALM | Art S-1 |
| CON-Z3-AS-01-EW-0020 |  | Installation of Cables |  | 10d | 2017-04-27 | 2017-05-09 | CON-Z3-AS-01-EW-0010 | 90.8d | 0d | Electrician [78 h]; LC Crew [52 h] | 1,097.12 | 1.3.8.50 | CONS | CONS | ZONE-3 | REALM | Art S-1 |
| CON-Z3-AS-01-EW-0030 |  | Installation of Junction Boxes |  | 8d | 2017-05-09 | 2017-05-18 | CON-Z3-AS-01-EW-0020 | 90.8d | 0d | Electrician [78 h]; LC Crew [52 h] | 548.56 | 1.3.8.50 | CONS | CONS | ZONE-3 | REALM | Art S-1 |
| CON-Z3-AS-01-EW-0040 |  | Installation of receptacle outlets and wiring devices |  | 12d | 2017-05-18 | 2017-06-01 | CON-Z3-AS-01-EW-0030 | 90.8d | 0d | Electrician [78 h]; LC Crew [52 h] | 1,919.96 | 1.3.8.50 | CONS | CONS | ZONE-3 | REALM | Art S-1 |
| CON-Z3-AS-01-EW-0050 |  | Installation of Internal and External Lighting Fixures |  | 16d | 2017-06-01 | 2017-06-20 | CON-Z3-AS-01-EW-0040 | 90.8d | 0d | Electrician [78 h]; LC Crew [52 h] | 1,371.4 | 1.3.8.50 | CONS | CONS | ZONE-3 | REALM | Art S-1 |
|  | 5 | **External Works** |  |  | 2017-06-20 | 2017-07-04 |  |  |  |  |  |  |  |  |  |  |  |
| CON-Z3-AS-01-EXT-010 |  | Installation of Building Signage |  | 8d | 2017-06-20 | 2017-07-04 | CON-Z3-AS-01-EW-0050 | 98.8d | 8d | Shuttering Carpenter [26 h]; Common Labor / Helper [52 h] | 822.84 | 1.3.8.50 | CONS | CONS | ZONE-3 | REALM | Art S-1 |

Notes:
- CON-Z3-AS-01-CW-0020: Expenses: (New Expense Item) 1316.55
- CON-Z3-AS-01-CW-0030: Expenses: (New Expense Item) 1974.82
- CON-Z3-AS-01-AR-0010: Expenses: (New Expense Item) 822.84
- CON-Z3-AS-01-AR-0020: Expenses: (New Expense Item) 1097.12
- CON-Z3-AS-01-AR-0030: Expenses: (New Expense Item) 2194.24
- CON-Z3-AS-01-AR-0040: Expenses: (New Expense Item) 1371.4
- CON-Z3-AS-01-ME-0010: Expenses: (New Expense Item) 4114.21
- CON-Z3-AS-01-ME-0020: Expenses: (New Expense Item) 1234.26
- CON-Z3-AS-01-ME-0040: Expenses: (New Expense Item) 822.84
- CON-Z3-AS-01-ME-0050: Expenses: (New Expense Item) 822.84
- CON-Z3-AS-01-ME-0030: Expenses: (New Expense Item) 1234.26
- CON-Z3-AS-01-EW-0010: Expenses: (New Expense Item) 548.56
- CON-Z3-AS-01-EW-0020: Expenses: (New Expense Item) 1097.12
- CON-Z3-AS-01-EW-0030: Expenses: (New Expense Item) 548.56
- CON-Z3-AS-01-EW-0040: Expenses: (New Expense Item) 1919.96
- CON-Z3-AS-01-EW-0050: Expenses: (New Expense Item) 1371.4
- CON-Z3-AS-01-EXT-010: Expenses: (New Expense Item) 822.84

| ID | WBS | Activity | Type | Duration | Start | Finish | Predecessors | Total float | Free float | Resources | Cost | RPI_P2 - BOQ ITEMS | RPI_P2 - CONSTRUCTION | RPI_P2 - PHASE | RPI_P2 - ZONES | RPI_P2 - AREAS | RPI_P2 - BUILDINGS |
| --- | --- | --- | --- | --- | --- | --- | --- | --- | --- | --- | --- | --- | --- | --- | --- | --- | --- |
|  | 6 | **Testing and Precommissioning** |  |  | 2017-05-09 | 2017-07-13 |  |  |  |  |  |  |  |  |  |  |  |
| CON-Z3-AS-01-TC-0020 |  | Testing and Precommissioning of Mechanical Work |  | 12d | 2017-05-09 | 2017-05-23 | CON-Z3-AS-01-ME-0050 | 130.8d | 40d | Mechanical Technician [78 h]; Common Labor / Helper [26 h]; HVAC Crew [26 h] | 822.84 | 1.3.8.50 | CONS | CONS | ZONE-3 | REALM | Art S-1 |
| CON-Z3-AS-01-TC-0010 |  | Testing and Precommissioning of Plumbing Work |  | 12d | 2017-05-21 | 2017-06-04 | CON-Z3-AS-01-ME-0010, CON-Z3-AS-01-ME-0030 | 120.8d | 30d | Plumber [78 h]; Common Labor / Helper [52 h] | 2,057.1 | 1.3.8.50 | CONS | CONS | ZONE-3 | REALM | Art S-1 |
| CON-Z3-AS-01-TC-0030 |  | Testing and Precommissioning of Electrical Work |  | 16d | 2017-06-20 | 2017-07-13 | CON-Z3-AS-01-EW-0050 | 90.8d | 0d | Electrician [78 h]; Common Labor / Helper [26 h] | 1,234.26 | 1.3.8.50 | CONS | CONS | ZONE-3 | REALM | Art S-1 |
| CON-Z3-AS-01-TC-0040 |  | Finish of Art Works Shelter # 01 | milestone | 0d | 2017-07-13 | 2017-07-13 | CON-Z3-AS-01-TC-0010, CON-Z3-AS-01-TC-0020, CON-Z3-AS-01-EXT-010, CON-Z3-AS-01-TC-0030, CON-Z3-AS-01-AR-0040 | 90.8d | 90.6d |  |  | 1.3.8.50 | CONS | CONS | ZONE-3 | REALM | Art S-1 |
|  | 1 | **Art Works Shelter # 02** |  |  | 2017-03-06 | 2017-09-09 |  |  |  |  |  |  |  |  |  |  |  |
|  | 1 | **Civil / Structural Works** |  |  | 2017-03-06 | 2017-04-04 |  |  |  |  |  |  |  |  |  |  |  |
| CON-Z3-AS-02-CW-0010 |  | Start of Art Works Shelter # 02 | milestone | 0d | 2017-03-06 | 2017-03-06 | CON-Z3-AS-01-CW-0010 FS+10d | 20.8d | 0d |  |  | 1.3.8.50 | CONS | CONS | ZONE-3 | REALM | Art S-2 |
| CON-Z3-AS-02-CW-0020 |  | General Backfilling |  | 10d | 2017-03-06 | 2017-03-18 | CON-Z3-AS-02-CW-0010 | 45.8d | 0d | Common Labor / Helper [78 h]; Operator - Loader [26 h]; Driver - Dump Truck [26 h]; Operator - Bobcat [26 h]; Operator - Roller-Compactor (2~10 Ton) [26 h]; Operator - Roller (25 Ton) [26 h]; Driver - Water Tanker [26 h]; Loader [28 h]; Dump Truck [28 h]; Bobcat [28 h]; Roller-Compactor (2~10 Ton) [28 h]; Roller-Compactor (25 Ton) [28 h]; Water Tanker [28 h] | 1,316.55 | 1.3.8.50 | CONS | CONS | ZONE-3 | REALM | Art S-2 |
| CON-Z3-AS-02-CW-0030 |  | Installation of Slab on Garde |  | 15d | 2017-03-18 | 2017-04-04 | CON-Z3-AS-02-CW-0020 | 45.8d | 0d | Steel Fixer [52 h]; Shuttering Carpenter [78 h]; Concrete Mason [78 h]; Common Labor / Helper [78 h] | 1,974.82 | 1.3.8.50 | CONS | CONS | ZONE-3 | REALM | Art S-2 |
|  | 2 | **Architectural & Finishes** |  |  | 2017-04-04 | 2017-05-27 |  |  |  |  |  |  |  |  |  |  |  |
| CON-Z3-AS-02-AR-0020 |  | Plastering Work Internal and External |  | 15d | 2017-04-04 | 2017-04-22 | CON-Z3-AS-02-CW-0030 | 45.8d | 0d | Concrete Mason [78 h]; Common Labor / Helper [26 h]; Scaffolder [26 h]; Finishing Work Crew [52 h] | 1,097.12 | 1.3.8.50 | CONS | CONS | ZONE-3 | REALM | Art S-2 |
| CON-Z3-AS-02-AR-0040 |  | Installation of Concrete Topping and Floor Finishes |  | 10d | 2017-04-22 | 2017-05-03 | CON-Z3-AS-02-AR-0020 | 45.8d | 0d | Common Labor / Helper [52 h]; Finishing Work Crew [52 h] | 1,371.4 | 1.3.8.50 | CONS | CONS | ZONE-3 | REALM | Art S-2 |
| CON-Z3-AS-02-AR-0010 |  | Installation of Wooden Roof Trellis and other Wood Works |  | 10d | 2017-05-03 | 2017-05-15 | CON-Z3-AS-02-AR-0040 | 45.8d | 0d | Shuttering Carpenter [52 h]; Common Labor / Helper [78 h]; Scaffolder [52 h]; Wood Works Crew [52 h] | 822.84 | 1.3.8.50 | CONS | CONS | ZONE-3 | REALM | Art S-2 |
| CON-Z3-AS-02-AR-0030 |  | Painting Work Internal and External |  | 10d | 2017-05-15 | 2017-05-27 | CON-Z3-AS-02-CW-0030, CON-Z3-AS-02-AR-0020, CON-Z3-AS-02-AR-0010 | 45.8d | 0d | Common Labor / Helper [26 h]; Scaffolder [52 h]; Painter [78 h] | 2,194.24 | 1.3.8.50 | CONS | CONS | ZONE-3 | REALM | Art S-2 |
|  | 3 | **Mechanical Works** |  |  | 2017-05-27 | 2017-07-17 |  |  |  |  |  |  |  |  |  |  |  |
| CON-Z3-AS-02-ME-0010 |  | Installation of Potable Water Supply System |  | 10d | 2017-05-27 | 2017-06-07 | CON-Z3-AS-02-AR-0030 | 45.8d | 0d | Plumber [78 h]; Common Labor / Helper [52 h] | 4,114.21 | 1.3.8.50 | CONS | CONS | ZONE-3 | REALM | Art S-2 |
| CON-Z3-AS-02-ME-0020 |  | Installation of Free Standing Sink with drain |  | 5d | 2017-06-07 | 2017-06-13 | CON-Z3-AS-02-ME-0010 | 75.8d | 0d | Plumber [26 h]; Common Labor / Helper [52 h] | 1,234.26 | 1.3.8.50 | CONS | CONS | ZONE-3 | REALM | Art S-2 |
| CON-Z3-AS-02-ME-0040 |  | Installation of Drinking Fountain and BBQ Grill |  | 10d | 2017-06-13 | 2017-06-25 | CON-Z3-AS-02-ME-0020 | 75.8d | 0d | Plumber [26 h]; Common Labor / Helper [52 h] | 822.84 | 1.3.8.50 | CONS | CONS | ZONE-3 | REALM | Art S-2 |
| CON-Z3-AS-02-ME-0050 |  | Installation of Fire Extinguisher |  | 5d | 2017-06-25 | 2017-07-05 | CON-Z3-AS-02-ME-0040 | 75.8d | 0d | Common Labor / Helper [52 h] | 822.84 | 1.3.8.50 | CONS | CONS | ZONE-3 | REALM | Art S-2 |
| CON-Z3-AS-02-ME-0030 |  | Instalaltion of Tie in Connection for Water Supply system |  | 10d | 2017-07-05 | 2017-07-17 | CON-Z3-AS-02-ME-0050, CON-Z3-AS-02-ME-0010 | 75.8d | 0d | Plumber [52 h]; Common Labor / Helper [52 h] | 1,234.26 | 1.3.8.50 | CONS | CONS | ZONE-3 | REALM | Art S-2 |
|  | 4 | **Electrical Works** |  |  | 2017-06-07 | 2017-08-16 |  |  |  |  |  |  |  |  |  |  |  |
| CON-Z3-AS-02-EW-0010 |  | Instalaltion of Conduits |  | 10d | 2017-06-07 | 2017-06-19 | CON-Z3-AS-02-ME-0010 | 45.8d | 0d | Electrician [78 h]; LC Crew [52 h] | 548.56 | 1.3.8.50 | CONS | CONS | ZONE-3 | REALM | Art S-2 |
| CON-Z3-AS-02-EW-0020 |  | Installation of Cables |  | 10d | 2017-06-19 | 2017-07-05 | CON-Z3-AS-02-EW-0010 | 45.8d | 0d | Electrician [78 h]; LC Crew [52 h] | 1,097.12 | 1.3.8.50 | CONS | CONS | ZONE-3 | REALM | Art S-2 |
| CON-Z3-AS-02-EW-0030 |  | Installation of Junction Boxes |  | 8d | 2017-07-05 | 2017-07-15 | CON-Z3-AS-02-EW-0020 | 45.8d | 0d | Electrician [78 h]; LC Crew [52 h] | 548.56 | 1.3.8.50 | CONS | CONS | ZONE-3 | REALM | Art S-2 |
| CON-Z3-AS-02-EW-0040 |  | Installation of receptacle outlets and wiring devices |  | 12d | 2017-07-15 | 2017-07-29 | CON-Z3-AS-02-EW-0030 | 45.8d | 0d | Electrician [78 h]; LC Crew [52 h] | 1,919.96 | 1.3.8.50 | CONS | CONS | ZONE-3 | REALM | Art S-2 |
| CON-Z3-AS-02-EW-0050 |  | Installation of Internal and External Lighting Fixures |  | 16d | 2017-07-29 | 2017-08-16 | CON-Z3-AS-02-EW-0040 | 45.8d | 0d | Electrician [78 h]; LC Crew [52 h] | 1,371.4 | 1.3.8.50 | CONS | CONS | ZONE-3 | REALM | Art S-2 |

Notes:
- CON-Z3-AS-01-TC-0020: Expenses: (New Expense Item) 822.84
- CON-Z3-AS-01-TC-0010: Expenses: (New Expense Item) 2057.1
- CON-Z3-AS-01-TC-0030: Expenses: (New Expense Item) 1234.26
- CON-Z3-AS-02-CW-0020: Expenses: (New Expense Item) 1316.55
- CON-Z3-AS-02-CW-0030: Expenses: (New Expense Item) 1974.82
- CON-Z3-AS-02-AR-0020: Expenses: (New Expense Item) 1097.12
- CON-Z3-AS-02-AR-0040: Expenses: (New Expense Item) 1371.4
- CON-Z3-AS-02-AR-0010: Expenses: (New Expense Item) 822.84
- CON-Z3-AS-02-AR-0030: Expenses: (New Expense Item) 2194.24
- CON-Z3-AS-02-ME-0010: Expenses: (New Expense Item) 4114.21
- CON-Z3-AS-02-ME-0020: Expenses: (New Expense Item) 1234.26
- CON-Z3-AS-02-ME-0040: Expenses: (New Expense Item) 822.84
- CON-Z3-AS-02-ME-0050: Expenses: (New Expense Item) 822.84
- CON-Z3-AS-02-ME-0030: Expenses: (New Expense Item) 1234.26
- CON-Z3-AS-02-EW-0010: Expenses: (New Expense Item) 548.56
- CON-Z3-AS-02-EW-0020: Expenses: (New Expense Item) 1097.12
- CON-Z3-AS-02-EW-0030: Expenses: (New Expense Item) 548.56
- CON-Z3-AS-02-EW-0040: Expenses: (New Expense Item) 1919.96
- CON-Z3-AS-02-EW-0050: Expenses: (New Expense Item) 1371.4

| ID | WBS | Activity | Type | Duration | Start | Finish | Predecessors | Total float | Free float | Resources | Cost | RPI_P2 - BOQ ITEMS | RPI_P2 - CONSTRUCTION | RPI_P2 - PHASE | RPI_P2 - ZONES | RPI_P2 - AREAS | RPI_P2 - BUILDINGS |
| --- | --- | --- | --- | --- | --- | --- | --- | --- | --- | --- | --- | --- | --- | --- | --- | --- | --- |
|  | 5 | **External Works** |  |  | 2017-08-16 | 2017-08-26 |  |  |  |  |  |  |  |  |  |  |  |
| CON-Z3-AS-02-EXT-010 |  | Installation of Building Signage |  | 8d | 2017-08-16 | 2017-08-26 | CON-Z3-AS-02-EW-0050 | 53.8d | 8d | Shuttering Carpenter [26 h]; Common Labor / Helper [52 h] | 822.84 | 1.3.8.50 | CONS | CONS | ZONE-3 | REALM | Art S-2 |
|  | 6 | **Testing and Precommissioning** |  |  | 2017-07-05 | 2017-09-09 |  |  |  |  |  |  |  |  |  |  |  |
| CON-Z3-AS-02-TC-0040 |  | Testing and Precommissioning of Mechanical Work |  | 12d | 2017-07-05 | 2017-07-19 | CON-Z3-AS-02-ME-0050 | 85.8d | 40d | Mechanical Technician [78 h]; Common Labor / Helper [26 h]; HVAC Crew [26 h] |  | 1.3.8.50 | CONS | CONS | ZONE-3 | REALM | Art S-2 |
| CON-Z3-AS-02-TC-0030 |  | Testing and Precommissioning of Plumbing Work |  | 12d | 2017-07-17 | 2017-07-31 | CON-Z3-AS-02-ME-0030, CON-Z3-AS-02-ME-0010 | 75.8d | 30d | Plumber [78 h]; Common Labor / Helper [52 h] | 1,234.26 | 1.3.8.50 | CONS | CONS | ZONE-3 | REALM | Art S-2 |
| CON-Z3-AS-02-TC-0010 |  | Testing and Precommissioning of Electrical Work |  | 16d | 2017-08-16 | 2017-09-09 | CON-Z3-AS-02-EW-0050 | 45.8d | 0d | Electrician [78 h]; Common Labor / Helper [26 h] | 2,057.1 | 1.3.8.50 | CONS | CONS | ZONE-3 | REALM | Art S-2 |
| CON-Z3-AS-02-TC-0020 |  | Finish of Art Works Shelter # 02 | milestone | 0d | 2017-09-09 | 2017-09-09 | CON-Z3-AS-02-EXT-010, CON-Z3-AS-02-TC-0030, CON-Z3-AS-02-TC-0010, CON-Z3-AS-02-TC-0040 | 45.8d | 45.6d |  | 822.84 | 1.3.8.50 | CONS | CONS | ZONE-3 | REALM | Art S-2 |
|  | 2 | **Art Works Shelter # 03** |  |  | 2017-03-18 | 2017-08-06 |  |  |  |  |  |  |  |  |  |  |  |
|  | 1 | **Civil / Structural Works** |  |  | 2017-03-18 | 2017-04-16 |  |  |  |  |  |  |  |  |  |  |  |
| CON-Z3-AS-03-CW-0010 |  | Start of Art Works Shelter # 03 | milestone | 0d | 2017-03-18 | 2017-03-18 | CON-Z3-AS-02-CW-0010 FS+10d | 20.8d | 0d |  |  | 1.3.8.50 | CONS | CONS | ZONE-3 | REALM | Art S-3 |
| CON-Z3-AS-03-CW-0020 |  | General Backfilling |  | 10d | 2017-03-18 | 2017-03-29 | CON-Z3-AS-03-CW-0010 | 70.8d | 0d | Operator - Roller (25 Ton) [26 h]; Driver - Water Tanker [26 h]; Loader [28 h]; Dump Truck [28 h]; Bobcat [28 h]; Roller-Compactor (2~10 Ton) [28 h]; Roller-Compactor (25 Ton) [28 h]; Water Tanker [28 h]; Common Labor / Helper [78 h]; Operator - Loader [26 h]; Driver - Dump Truck [26 h]; Operator - Bobcat [26 h]; Operator - Roller-Compactor (2~10 Ton) [26 h] | 1,316.55 | 1.3.8.50 | CONS | CONS | ZONE-3 | REALM | Art S-3 |
| CON-Z3-AS-03-CW-0030 |  | Installation of Slab on Garde |  | 15d | 2017-03-29 | 2017-04-16 | CON-Z3-AS-03-CW-0020 | 70.8d | 0d | Steel Fixer [52 h]; Shuttering Carpenter [78 h]; Concrete Mason [78 h]; Common Labor / Helper [78 h] | 1,974.82 | 1.3.8.50 | CONS | CONS | ZONE-3 | REALM | Art S-3 |
|  | 2 | **Architectural & Finishes** |  |  | 2017-04-16 | 2017-06-07 |  |  |  |  |  |  |  |  |  |  |  |
| CON-Z3-AS-03-AR-0010 |  | Plastering Work Internal and External |  | 10d | 2017-04-16 | 2017-04-27 | CON-Z3-AS-03-CW-0030 | 70.8d | 0d | Concrete Mason [78 h]; Common Labor / Helper [26 h]; Scaffolder [26 h]; Finishing Work Crew [52 h] | 822.84 | 1.3.8.50 | CONS | CONS | ZONE-3 | REALM | Art S-3 |
| CON-Z3-AS-03-AR-0020 |  | Installation of Concrete Topping and Floor Finishes |  | 10d | 2017-04-27 | 2017-05-09 | CON-Z3-AS-03-AR-0010 | 117.8d | 0d | Common Labor / Helper [52 h]; Finishing Work Crew [52 h] | 1,097.12 | 1.3.8.50 | CONS | CONS | ZONE-3 | REALM | Art S-3 |
| CON-Z3-AS-03-AR-0030 |  | Installation of Wooden Roof Trellis and other Wood Works |  | 10d | 2017-05-09 | 2017-05-21 | CON-Z3-AS-03-AR-0020 | 117.8d | 0d | Shuttering Carpenter [52 h]; Common Labor / Helper [78 h]; Scaffolder [52 h]; Wood Works Crew [52 h] | 2,194.24 | 1.3.8.50 | CONS | CONS | ZONE-3 | REALM | Art S-3 |
| CON-Z3-AS-03-AR-0040 |  | Painting Work Internal and External |  | 15d | 2017-05-21 | 2017-06-07 | CON-Z3-AS-03-AR-0030, CON-Z3-AS-03-ME-0010 FF+5d | 117.8d | 47d | Common Labor / Helper [26 h]; Scaffolder [52 h]; Painter [78 h] | 1,371.4 | 1.3.8.50 | CONS | CONS | ZONE-3 | REALM | Art S-3 |
|  | 3 | **Mechanical Works** |  |  | 2017-04-27 | 2017-06-13 |  |  |  |  |  |  |  |  |  |  |  |
| CON-Z3-AS-03-ME-0010 |  | Installation of Potable Water Supply System |  | 10d | 2017-04-27 | 2017-05-09 | CON-Z3-AS-03-AR-0010 | 70.8d | 0d | Plumber [78 h]; Common Labor / Helper [52 h] | 4,114.21 | 1.3.8.50 | CONS | CONS | ZONE-3 | REALM | Art S-3 |
| CON-Z3-AS-03-ME-0020 |  | Installation of Free Standing Sink with drain |  | 5d | 2017-05-09 | 2017-05-15 | CON-Z3-AS-03-ME-0010 | 100.8d | 0d | Plumber [26 h]; Common Labor / Helper [52 h] | 1,234.26 | 1.3.8.50 | CONS | CONS | ZONE-3 | REALM | Art S-3 |
| CON-Z3-AS-03-ME-0040 |  | Installation of Drinking Fountain and BBQ Grill |  | 10d | 2017-05-15 | 2017-05-27 | CON-Z3-AS-03-ME-0020 | 100.8d | 0d | Plumber [26 h]; Common Labor / Helper [52 h] | 822.84 | 1.3.8.50 | CONS | CONS | ZONE-3 | REALM | Art S-3 |
| CON-Z3-AS-03-ME-0050 |  | Installation of Fire Extinguisher |  | 5d | 2017-05-27 | 2017-06-01 | CON-Z3-AS-03-ME-0040 | 100.8d | 0d | Common Labor / Helper [52 h] | 822.84 | 1.3.8.50 | CONS | CONS | ZONE-3 | REALM | Art S-3 |
| CON-Z3-AS-03-ME-0030 |  | Instalaltion of Tie in Connection for Water Supply system |  | 10d | 2017-06-01 | 2017-06-13 | CON-Z3-AS-03-ME-0050, CON-Z3-AS-03-ME-0010 | 100.8d | 0d | Plumber [52 h]; Common Labor / Helper [52 h] | 1,234.26 | 1.3.8.50 | CONS | CONS | ZONE-3 | REALM | Art S-3 |
|  | 4 | **Electrical Works** |  |  | 2017-05-09 | 2017-07-18 |  |  |  |  |  |  |  |  |  |  |  |
| CON-Z3-AS-03-EW-0010 |  | Instalaltion of Conduits |  | 10d | 2017-05-09 | 2017-05-21 | CON-Z3-AS-03-ME-0010 | 70.8d | 0d | Electrician [78 h]; LC Crew [52 h] | 548.56 | 1.3.8.50 | CONS | CONS | ZONE-3 | REALM | Art S-3 |
| CON-Z3-AS-03-EW-0020 |  | Installation of Cables |  | 10d | 2017-05-21 | 2017-06-01 | CON-Z3-AS-03-EW-0010 | 70.8d | 0d | Electrician [78 h]; LC Crew [52 h] | 1,097.12 | 1.3.8.50 | CONS | CONS | ZONE-3 | REALM | Art S-3 |
| CON-Z3-AS-03-EW-0030 |  | Installation of Junction Boxes |  | 8d | 2017-06-01 | 2017-06-11 | CON-Z3-AS-03-EW-0020 | 70.8d | 0d | Electrician [78 h]; LC Crew [52 h] | 548.56 | 1.3.8.50 | CONS | CONS | ZONE-3 | REALM | Art S-3 |
| CON-Z3-AS-03-EW-0040 |  | Installation of receptacle outlets and wiring devices |  | 12d | 2017-06-11 | 2017-06-25 | CON-Z3-AS-03-EW-0030 | 70.8d | 0d | Electrician [78 h]; LC Crew [52 h] | 1,919.96 | 1.3.8.50 | CONS | CONS | ZONE-3 | REALM | Art S-3 |
| CON-Z3-AS-03-EW-0050 |  | Installation of Internal and External Lighting Fixures |  | 16d | 2017-06-25 | 2017-07-18 | CON-Z3-AS-03-EW-0040 | 70.8d | 0d | Electrician [78 h]; LC Crew [52 h] | 1,371.4 | 1.3.8.50 | CONS | CONS | ZONE-3 | REALM | Art S-3 |

Notes:
- CON-Z3-AS-02-EXT-010: Expenses: (New Expense Item) 822.84
- CON-Z3-AS-02-TC-0030: Expenses: (New Expense Item) 1234.26
- CON-Z3-AS-02-TC-0010: Expenses: (New Expense Item) 2057.1
- CON-Z3-AS-02-TC-0020: Expenses: (New Expense Item) 822.84
- CON-Z3-AS-03-CW-0020: Expenses: (New Expense Item) 1316.55
- CON-Z3-AS-03-CW-0030: Expenses: (New Expense Item) 1974.82
- CON-Z3-AS-03-AR-0010: Expenses: (New Expense Item) 822.84
- CON-Z3-AS-03-AR-0020: Expenses: (New Expense Item) 1097.12
- CON-Z3-AS-03-AR-0030: Expenses: (New Expense Item) 2194.24
- CON-Z3-AS-03-AR-0040: Expenses: (New Expense Item) 1371.4
- CON-Z3-AS-03-ME-0010: Expenses: (New Expense Item) 4114.21
- CON-Z3-AS-03-ME-0020: Expenses: (New Expense Item) 1234.26
- CON-Z3-AS-03-ME-0040: Expenses: (New Expense Item) 822.84
- CON-Z3-AS-03-ME-0050: Expenses: (New Expense Item) 822.84
- CON-Z3-AS-03-ME-0030: Expenses: (New Expense Item) 1234.26
- CON-Z3-AS-03-EW-0010: Expenses: (New Expense Item) 548.56
- CON-Z3-AS-03-EW-0020: Expenses: (New Expense Item) 1097.12
- CON-Z3-AS-03-EW-0030: Expenses: (New Expense Item) 548.56
- CON-Z3-AS-03-EW-0040: Expenses: (New Expense Item) 1919.96
- CON-Z3-AS-03-EW-0050: Expenses: (New Expense Item) 1371.4

| ID | WBS | Activity | Type | Duration | Start | Finish | Predecessors | Total float | Free float | Resources | Cost | RPI_P2 - BOQ ITEMS | RPI_P2 - CONSTRUCTION | RPI_P2 - PHASE | RPI_P2 - ZONES | RPI_P2 - AREAS | RPI_P2 - BUILDINGS |
| --- | --- | --- | --- | --- | --- | --- | --- | --- | --- | --- | --- | --- | --- | --- | --- | --- | --- |
|  | 5 | **External Works** |  |  | 2017-07-18 | 2017-07-27 |  |  |  |  |  |  |  |  |  |  |  |
| CON-Z3-AS-03-EXT-010 |  | Installation of Building Signage |  | 8d | 2017-07-18 | 2017-07-27 | CON-Z3-AS-03-EW-0050 | 78.8d | 8d | Shuttering Carpenter [26 h]; Common Labor / Helper [52 h] | 822.84 | 1.3.8.50 | CONS | CONS | ZONE-3 | REALM | Art S-3 |
|  | 6 | **Testing and Precommissioning** |  |  | 2017-06-01 | 2017-08-06 |  |  |  |  |  |  |  |  |  |  |  |
| CON-Z3-AS-03-TC-0020 |  | Testing and Precommissioning of Mechanical Work |  | 12d | 2017-06-01 | 2017-06-15 | CON-Z3-AS-03-ME-0050 | 110.8d | 40d | Mechanical Technician [78 h]; Common Labor / Helper [26 h]; HVAC Crew [26 h] | 822.84 | 1.3.8.50 | CONS | CONS | ZONE-3 | REALM | Art S-3 |
| CON-Z3-AS-03-TC-0010 |  | Testing and Precommissioning of Plumbing Work |  | 12d | 2017-06-13 | 2017-07-02 | CON-Z3-AS-03-ME-0030, CON-Z3-AS-03-ME-0010 | 100.8d | 30d | Plumber [78 h]; Common Labor / Helper [52 h] | 2,057.1 | 1.3.8.50 | CONS | CONS | ZONE-3 | REALM | Art S-3 |
| CON-Z3-AS-03-TC-0030 |  | Testing and Precommissioning of Electrical Work |  | 16d | 2017-07-18 | 2017-08-06 | CON-Z3-AS-03-EW-0050 | 70.8d | 0d | Electrician [78 h]; Common Labor / Helper [26 h] | 1,234.26 | 1.3.8.50 | CONS | CONS | ZONE-3 | REALM | Art S-3 |
| CON-Z3-AS-03-TC-0040 |  | Finish of Art Works Shelter # 03 | milestone | 0d | 2017-08-06 | 2017-08-06 | CON-Z3-AS-03-TC-0030, CON-Z3-AS-03-AR-0040, CON-Z3-AS-03-EXT-010, CON-Z3-AS-03-TC-0010, CON-Z3-AS-03-TC-0020 | 70.8d | 70.6d |  |  | 1.3.8.50 | CONS | CONS | ZONE-3 | REALM | Art S-3 |
|  | 3 | **Art Works Shelter # 04** |  |  | 2017-03-29 | 2017-08-17 |  |  |  |  |  |  |  |  |  |  |  |
|  | 1 | **Civil / Structural Works** |  |  | 2017-03-29 | 2017-04-27 |  |  |  |  |  |  |  |  |  |  |  |
| CON-Z3-AS-04-CW-0010 |  | Start of Art Works Shelter # 04 | milestone | 0d | 2017-03-29 | 2017-03-29 | CON-Z3-AS-03-CW-0010 FS+10d | 20.8d | 0d |  |  | 1.3.8.50 | CONS | CONS | ZONE-3 | REALM | Art S-4 |
| CON-Z3-AS-04-CW-0020 |  | General Backfilling |  | 10d | 2017-03-29 | 2017-04-10 | CON-Z3-AS-04-CW-0010 | 60.8d | 0d | Common Labor / Helper [78 h]; Operator - Loader [26 h]; Driver - Dump Truck [26 h]; Operator - Bobcat [26 h]; Operator - Roller-Compactor (2~10 Ton) [26 h]; Operator - Roller (25 Ton) [26 h]; Driver - Water Tanker [26 h]; Loader [28 h]; Dump Truck [28 h]; Bobcat [28 h]; Roller-Compactor (2~10 Ton) [28 h]; Roller-Compactor (25 Ton) [28 h]; Water Tanker [28 h] | 1,316.55 | 1.3.8.50 | CONS | CONS | ZONE-3 | REALM | Art S-4 |
| CON-Z3-AS-04-CW-0030 |  | Installation of Slab on Garde |  | 15d | 2017-04-10 | 2017-04-27 | CON-Z3-AS-04-CW-0020 | 60.8d | 0d | Steel Fixer [52 h]; Shuttering Carpenter [78 h]; Concrete Mason [78 h]; Common Labor / Helper [78 h] | 1,974.82 | 1.3.8.50 | CONS | CONS | ZONE-3 | REALM | Art S-4 |
|  | 2 | **Architectural & Finishes** |  |  | 2017-04-27 | 2017-06-19 |  |  |  |  |  |  |  |  |  |  |  |
| CON-Z3-AS-04-AR-0010 |  | Plastering Work Internal and External |  | 10d | 2017-04-27 | 2017-05-09 | CON-Z3-AS-04-CW-0030 | 60.8d | 0d | Concrete Mason [78 h]; Common Labor / Helper [26 h]; Scaffolder [26 h]; Finishing Work Crew [52 h] | 822.84 | 1.3.8.50 | CONS | CONS | ZONE-3 | REALM | Art S-4 |
| CON-Z3-AS-04-AR-0020 |  | Installation of Concrete Topping and Floor Finishes |  | 10d | 2017-05-09 | 2017-05-21 | CON-Z3-AS-04-AR-0010 | 107.8d | 0d | Common Labor / Helper [52 h]; Finishing Work Crew [52 h] | 1,097.12 | 1.3.8.50 | CONS | CONS | ZONE-3 | REALM | Art S-4 |
| CON-Z3-AS-04-AR-0030 |  | Installation of Wooden Roof Trellis and other Wood Works |  | 10d | 2017-05-21 | 2017-06-01 | CON-Z3-AS-04-AR-0020 | 107.8d | 0d | Shuttering Carpenter [52 h]; Common Labor / Helper [78 h]; Scaffolder [52 h]; Wood Works Crew [52 h] | 2,194.24 | 1.3.8.50 | CONS | CONS | ZONE-3 | REALM | Art S-4 |
| CON-Z3-AS-04-AR-0040 |  | Painting Work Internal and External |  | 15d | 2017-06-01 | 2017-06-19 | CON-Z3-AS-04-ME-0010 FF+5d, CON-Z3-AS-04-AR-0030 | 107.8d | 47d | Common Labor / Helper [26 h]; Scaffolder [52 h]; Painter [78 h] | 1,371.4 | 1.3.8.50 | CONS | CONS | ZONE-3 | REALM | Art S-4 |
|  | 3 | **Mechanical Works** |  |  | 2017-05-09 | 2017-06-25 |  |  |  |  |  |  |  |  |  |  |  |
| CON-Z3-AS-04-ME-0010 |  | Installation of Potable Water Supply System |  | 10d | 2017-05-09 | 2017-05-21 | CON-Z3-AS-04-AR-0010 | 60.8d | 0d | Plumber [78 h]; Common Labor / Helper [52 h] | 4,114.21 | 1.3.8.50 | CONS | CONS | ZONE-3 | REALM | Art S-4 |
| CON-Z3-AS-04-ME-0020 |  | Installation of Free Standing Sink with drain |  | 5d | 2017-05-21 | 2017-05-27 | CON-Z3-AS-04-ME-0010 | 90.8d | 0d | Plumber [26 h]; Common Labor / Helper [52 h] | 1,234.26 | 1.3.8.50 | CONS | CONS | ZONE-3 | REALM | Art S-4 |
| CON-Z3-AS-04-ME-0040 |  | Installation of Drinking Fountain and BBQ Grill |  | 10d | 2017-05-27 | 2017-06-07 | CON-Z3-AS-04-ME-0020 | 90.8d | 0d | Plumber [26 h]; Common Labor / Helper [52 h] | 822.84 | 1.3.8.50 | CONS | CONS | ZONE-3 | REALM | Art S-4 |
| CON-Z3-AS-04-ME-0050 |  | Installation of Fire Extinguisher |  | 5d | 2017-06-07 | 2017-06-13 | CON-Z3-AS-04-ME-0040 | 90.8d | 0d | Common Labor / Helper [52 h] | 822.84 | 1.3.8.50 | CONS | CONS | ZONE-3 | REALM | Art S-4 |
| CON-Z3-AS-04-ME-0030 |  | Instalaltion of Tie in Connection for Water Supply system |  | 10d | 2017-06-13 | 2017-06-25 | CON-Z3-AS-04-ME-0010, CON-Z3-AS-04-ME-0050 | 90.8d | 0d | Plumber [52 h]; Common Labor / Helper [52 h] | 1,234.26 | 1.3.8.50 | CONS | CONS | ZONE-3 | REALM | Art S-4 |
|  | 4 | **Electrical Works** |  |  | 2017-05-21 | 2017-07-30 |  |  |  |  |  |  |  |  |  |  |  |
| CON-Z3-AS-04-EW-0010 |  | Instalaltion of Conduits |  | 10d | 2017-05-21 | 2017-06-01 | CON-Z3-AS-04-ME-0010 | 60.8d | 0d | Electrician [78 h]; LC Crew [52 h] | 548.56 | 1.3.8.50 | CONS | CONS | ZONE-3 | REALM | Art S-4 |
| CON-Z3-AS-04-EW-0020 |  | Installation of Cables |  | 10d | 2017-06-01 | 2017-06-13 | CON-Z3-AS-04-EW-0010 | 60.8d | 0d | Electrician [78 h]; LC Crew [52 h] | 1,097.12 | 1.3.8.50 | CONS | CONS | ZONE-3 | REALM | Art S-4 |
| CON-Z3-AS-04-EW-0030 |  | Installation of Junction Boxes |  | 8d | 2017-06-13 | 2017-06-22 | CON-Z3-AS-04-EW-0020 | 60.8d | 0d | Electrician [78 h]; LC Crew [52 h] | 548.56 | 1.3.8.50 | CONS | CONS | ZONE-3 | REALM | Art S-4 |
| CON-Z3-AS-04-EW-0040 |  | Installation of receptacle outlets and wiring devices |  | 12d | 2017-06-22 | 2017-07-11 | CON-Z3-AS-04-EW-0030 | 60.8d | 0d | Electrician [78 h]; LC Crew [52 h] | 1,919.96 | 1.3.8.50 | CONS | CONS | ZONE-3 | REALM | Art S-4 |
| CON-Z3-AS-04-EW-0050 |  | Installation of Internal and External Lighting Fixures |  | 16d | 2017-07-11 | 2017-07-30 | CON-Z3-AS-04-EW-0040 | 60.8d | 0d | Electrician [78 h]; LC Crew [52 h] | 1,371.4 | 1.3.8.50 | CONS | CONS | ZONE-3 | REALM | Art S-4 |

Notes:
- CON-Z3-AS-03-EXT-010: Expenses: (New Expense Item) 822.84
- CON-Z3-AS-03-TC-0020: Expenses: (New Expense Item) 822.84
- CON-Z3-AS-03-TC-0010: Expenses: (New Expense Item) 2057.1
- CON-Z3-AS-03-TC-0030: Expenses: (New Expense Item) 1234.26
- CON-Z3-AS-04-CW-0020: Expenses: (New Expense Item) 1316.55
- CON-Z3-AS-04-CW-0030: Expenses: (New Expense Item) 1974.82
- CON-Z3-AS-04-AR-0010: Expenses: (New Expense Item) 822.84
- CON-Z3-AS-04-AR-0020: Expenses: (New Expense Item) 1097.12
- CON-Z3-AS-04-AR-0030: Expenses: (New Expense Item) 2194.24
- CON-Z3-AS-04-AR-0040: Expenses: (New Expense Item) 1371.4
- CON-Z3-AS-04-ME-0010: Expenses: (New Expense Item) 4114.21
- CON-Z3-AS-04-ME-0020: Expenses: (New Expense Item) 1234.26
- CON-Z3-AS-04-ME-0040: Expenses: (New Expense Item) 822.84
- CON-Z3-AS-04-ME-0050: Expenses: (New Expense Item) 822.84
- CON-Z3-AS-04-ME-0030: Expenses: (New Expense Item) 1234.26
- CON-Z3-AS-04-EW-0010: Expenses: (New Expense Item) 548.56
- CON-Z3-AS-04-EW-0020: Expenses: (New Expense Item) 1097.12
- CON-Z3-AS-04-EW-0030: Expenses: (New Expense Item) 548.56
- CON-Z3-AS-04-EW-0040: Expenses: (New Expense Item) 1919.96
- CON-Z3-AS-04-EW-0050: Expenses: (New Expense Item) 1371.4

| ID | WBS | Activity | Type | Duration | Start | Finish | Predecessors | Total float | Free float | Resources | Cost | RPI_P2 - BOQ ITEMS | RPI_P2 - CONSTRUCTION | RPI_P2 - PHASE | RPI_P2 - ZONES | RPI_P2 - AREAS | RPI_P2 - BUILDINGS |
| --- | --- | --- | --- | --- | --- | --- | --- | --- | --- | --- | --- | --- | --- | --- | --- | --- | --- |
|  | 5 | **External Works** |  |  | 2017-07-30 | 2017-08-08 |  |  |  |  |  |  |  |  |  |  |  |
| CON-Z3-AS-04-EXT-010 |  | Installation of Building Signage |  | 8d | 2017-07-30 | 2017-08-08 | CON-Z3-AS-04-EW-0050 | 68.8d | 8d | Shuttering Carpenter [26 h]; Common Labor / Helper [52 h] | 822.84 | 1.3.8.50 | CONS | CONS | ZONE-3 | REALM | Art S-4 |
|  | 6 | **Testing and Precommissioning** |  |  | 2017-06-13 | 2017-08-17 |  |  |  |  |  |  |  |  |  |  |  |
| CON-Z3-AS-04-TC-0020 |  | Testing and Precommissioning of Mechanical Work |  | 12d | 2017-06-13 | 2017-07-02 | CON-Z3-AS-04-ME-0050 | 100.8d | 40d | Mechanical Technician [78 h]; Common Labor / Helper [26 h]; HVAC Crew [26 h] | 822.84 | 1.3.8.50 | CONS | CONS | ZONE-3 | REALM | Art S-4 |
| CON-Z3-AS-04-TC-0010 |  | Testing and Precommissioning of Plumbing Work |  | 12d | 2017-06-25 | 2017-07-13 | CON-Z3-AS-04-ME-0030, CON-Z3-AS-04-ME-0010 | 90.8d | 30d | Plumber [78 h]; Common Labor / Helper [52 h] | 2,057.1 | 1.3.8.50 | CONS | CONS | ZONE-3 | REALM | Art S-4 |
| CON-Z3-AS-04-TC-0030 |  | Testing and Precommissioning of Electrical Work |  | 16d | 2017-07-30 | 2017-08-17 | CON-Z3-AS-04-EW-0050 | 60.8d | 0d | Electrician [78 h]; Common Labor / Helper [26 h] | 1,234.26 | 1.3.8.50 | CONS | CONS | ZONE-3 | REALM | Art S-4 |
| CON-Z3-AS-04-TC-0040 |  | Finish of Art Works Shelter # 04 | milestone | 0d | 2017-08-17 | 2017-08-17 | CON-Z3-AS-04-EXT-010, CON-Z3-AS-04-TC-0010, CON-Z3-AS-04-TC-0020, CON-Z3-AS-04-AR-0040, CON-Z3-AS-04-TC-0030 | 60.8d | 60.6d |  |  | 1.3.8.50 | CONS | CONS | ZONE-3 | REALM | Art S-4 |
|  | 4 | **Art Works Shelter # 05** |  |  | 2017-04-10 | 2017-08-29 |  |  |  |  |  |  |  |  |  |  |  |
|  | 1 | **Civil / Structural Works** |  |  | 2017-04-10 | 2017-05-09 |  |  |  |  |  |  |  |  |  |  |  |
| CON-Z3-AS-05-CW-0010 |  | Start of Art Works Shelter # 05 | milestone | 0d | 2017-04-10 | 2017-04-10 | CON-Z3-AS-04-CW-0010 FS+10d | 20.8d | 0d |  |  | 1.3.8.50 | CONS | CONS | ZONE-3 | REALM | Art S-5 |
| CON-Z3-AS-05-CW-0020 |  | General Backfilling |  | 10d | 2017-04-10 | 2017-04-22 | CON-Z3-AS-05-CW-0010 | 50.8d | 0d | Common Labor / Helper [78 h]; Operator - Loader [26 h]; Driver - Dump Truck [26 h]; Operator - Bobcat [26 h]; Operator - Roller-Compactor (2~10 Ton) [26 h]; Operator - Roller (25 Ton) [26 h]; Driver - Water Tanker [26 h]; Loader [28 h]; Dump Truck [28 h]; Bobcat [28 h]; Roller-Compactor (2~10 Ton) [28 h]; Roller-Compactor (25 Ton) [28 h]; Water Tanker [28 h] | 1,316.55 | 1.3.8.50 | CONS | CONS | ZONE-3 | REALM | Art S-5 |
| CON-Z3-AS-05-CW-0030 |  | Installation of Slab on Garde |  | 15d | 2017-04-22 | 2017-05-09 | CON-Z3-AS-05-CW-0020 | 50.8d | 0d | Steel Fixer [52 h]; Shuttering Carpenter [78 h]; Concrete Mason [78 h]; Common Labor / Helper [78 h] | 1,974.82 | 1.3.8.50 | CONS | CONS | ZONE-3 | REALM | Art S-5 |
|  | 2 | **Architectural & Finishes** |  |  | 2017-05-09 | 2017-07-05 |  |  |  |  |  |  |  |  |  |  |  |
| CON-Z3-AS-05-AR-0010 |  | Plastering Work Internal and External |  | 10d | 2017-05-09 | 2017-05-21 | CON-Z3-AS-05-CW-0030 | 50.8d | 0d | Concrete Mason [78 h]; Common Labor / Helper [26 h]; Scaffolder [26 h]; Finishing Work Crew [52 h] | 822.84 | 1.3.8.50 | CONS | CONS | ZONE-3 | REALM | Art S-5 |
| CON-Z3-AS-05-AR-0020 |  | Installation of Concrete Topping and Floor Finishes |  | 10d | 2017-05-21 | 2017-06-01 | CON-Z3-AS-05-AR-0010 | 97.8d | 0d | Common Labor / Helper [52 h]; Finishing Work Crew [52 h] | 1,097.12 | 1.3.8.50 | CONS | CONS | ZONE-3 | REALM | Art S-5 |
| CON-Z3-AS-05-AR-0030 |  | Installation of Wooden Roof Trellis and other Wood Works |  | 10d | 2017-06-01 | 2017-06-13 | CON-Z3-AS-05-AR-0020 | 97.8d | 0d | Shuttering Carpenter [52 h]; Common Labor / Helper [78 h]; Scaffolder [52 h]; Wood Works Crew [52 h] | 2,194.24 | 1.3.8.50 | CONS | CONS | ZONE-3 | REALM | Art S-5 |
| CON-Z3-AS-05-AR-0040 |  | Painting Work Internal and External |  | 15d | 2017-06-13 | 2017-07-05 | CON-Z3-AS-05-ME-0010 FF+5d, CON-Z3-AS-05-AR-0030 | 97.8d | 47d | Common Labor / Helper [26 h]; Scaffolder [52 h]; Painter [78 h] | 1,371.4 | 1.3.8.50 | CONS | CONS | ZONE-3 | REALM | Art S-5 |
|  | 3 | **Mechanical Works** |  |  | 2017-05-21 | 2017-07-11 |  |  |  |  |  |  |  |  |  |  |  |
| CON-Z3-AS-05-ME-0010 |  | Installation of Potable Water Supply System |  | 10d | 2017-05-21 | 2017-06-01 | CON-Z3-AS-05-AR-0010 | 50.8d | 0d | Plumber [78 h]; Common Labor / Helper [52 h] | 4,114.21 | 1.3.8.50 | CONS | CONS | ZONE-3 | REALM | Art S-5 |
| CON-Z3-AS-05-ME-0020 |  | Installation of Free Standing Sink with drain |  | 5d | 2017-06-01 | 2017-06-07 | CON-Z3-AS-05-ME-0010 | 80.8d | 0d | Plumber [26 h]; Common Labor / Helper [52 h] | 1,234.26 | 1.3.8.50 | CONS | CONS | ZONE-3 | REALM | Art S-5 |
| CON-Z3-AS-05-ME-0040 |  | Installation of Drinking Fountain and BBQ Grill |  | 10d | 2017-06-07 | 2017-06-19 | CON-Z3-AS-05-ME-0020 | 80.8d | 0d | Plumber [26 h]; Common Labor / Helper [52 h] | 822.84 | 1.3.8.50 | CONS | CONS | ZONE-3 | REALM | Art S-5 |
| CON-Z3-AS-05-ME-0050 |  | Installation of Fire Extinguisher |  | 5d | 2017-06-19 | 2017-06-25 | CON-Z3-AS-05-ME-0040 | 80.8d | 0d | Common Labor / Helper [52 h] | 822.84 | 1.3.8.50 | CONS | CONS | ZONE-3 | REALM | Art S-5 |
| CON-Z3-AS-05-ME-0030 |  | Instalaltion of Tie in Connection for Water Supply system |  | 10d | 2017-06-25 | 2017-07-11 | CON-Z3-AS-05-ME-0010, CON-Z3-AS-05-ME-0050 | 80.8d | 0d | Plumber [52 h]; Common Labor / Helper [52 h] | 1,234.26 | 1.3.8.50 | CONS | CONS | ZONE-3 | REALM | Art S-5 |
|  | 4 | **Electrical Works** |  |  | 2017-06-01 | 2017-08-10 |  |  |  |  |  |  |  |  |  |  |  |
| CON-Z3-AS-05-EW-0010 |  | Instalaltion of Conduits |  | 10d | 2017-06-01 | 2017-06-13 | CON-Z3-AS-05-ME-0010 | 50.8d | 0d | Electrician [78 h]; LC Crew [52 h] | 548.56 | 1.3.8.50 | CONS | CONS | ZONE-3 | REALM | Art S-5 |
| CON-Z3-AS-05-EW-0020 |  | Installation of Cables |  | 10d | 2017-06-13 | 2017-06-25 | CON-Z3-AS-05-EW-0010 | 50.8d | 0d | Electrician [78 h]; LC Crew [52 h] | 1,097.12 | 1.3.8.50 | CONS | CONS | ZONE-3 | REALM | Art S-5 |
| CON-Z3-AS-05-EW-0030 |  | Installation of Junction Boxes |  | 8d | 2017-06-25 | 2017-07-09 | CON-Z3-AS-05-EW-0020 | 50.8d | 0d | Electrician [78 h]; LC Crew [52 h] | 548.56 | 1.3.8.50 | CONS | CONS | ZONE-3 | REALM | Art S-5 |
| CON-Z3-AS-05-EW-0050 |  | Installation of receptacle outlets and wiring devices |  | 12d | 2017-07-09 | 2017-07-23 | CON-Z3-AS-05-EW-0030 | 50.8d | 0d | Electrician [78 h]; LC Crew [52 h] | 1,919.96 | 1.3.8.50 | CONS | CONS | ZONE-3 | REALM | Art S-5 |
| CON-Z3-AS-05-EW-0060 |  | Installation of Internal and External Lighting Fixures |  | 16d | 2017-07-23 | 2017-08-10 | CON-Z3-AS-05-EW-0050 | 50.8d | 0d | Electrician [78 h]; LC Crew [52 h] | 1,371.4 | 1.3.8.50 | CONS | CONS | ZONE-3 | REALM | Art S-5 |

Notes:
- CON-Z3-AS-04-EXT-010: Expenses: (New Expense Item) 822.84
- CON-Z3-AS-04-TC-0020: Expenses: (New Expense Item) 822.84
- CON-Z3-AS-04-TC-0010: Expenses: (New Expense Item) 2057.1
- CON-Z3-AS-04-TC-0030: Expenses: (New Expense Item) 1234.26
- CON-Z3-AS-05-CW-0020: Expenses: (New Expense Item) 1316.55
- CON-Z3-AS-05-CW-0030: Expenses: (New Expense Item) 1974.82
- CON-Z3-AS-05-AR-0010: Expenses: (New Expense Item) 822.84
- CON-Z3-AS-05-AR-0020: Expenses: (New Expense Item) 1097.12
- CON-Z3-AS-05-AR-0030: Expenses: (New Expense Item) 2194.24
- CON-Z3-AS-05-AR-0040: Expenses: (New Expense Item) 1371.4
- CON-Z3-AS-05-ME-0010: Expenses: (New Expense Item) 4114.21
- CON-Z3-AS-05-ME-0020: Expenses: (New Expense Item) 1234.26
- CON-Z3-AS-05-ME-0040: Expenses: (New Expense Item) 822.84
- CON-Z3-AS-05-ME-0050: Expenses: (New Expense Item) 822.84
- CON-Z3-AS-05-ME-0030: Expenses: (New Expense Item) 1234.26
- CON-Z3-AS-05-EW-0010: Expenses: (New Expense Item) 548.56
- CON-Z3-AS-05-EW-0020: Expenses: (New Expense Item) 1097.12
- CON-Z3-AS-05-EW-0030: Expenses: (New Expense Item) 548.56
- CON-Z3-AS-05-EW-0050: Expenses: (New Expense Item) 1919.96
- CON-Z3-AS-05-EW-0060: Expenses: (New Expense Item) 1371.4

| ID | WBS | Activity | Type | Duration | Start | Finish | Predecessors | Total float | Free float | Resources | Cost | RPI_P2 - BOQ ITEMS | RPI_P2 - CONSTRUCTION | RPI_P2 - PHASE | RPI_P2 - ZONES | RPI_P2 - AREAS | RPI_P2 - BUILDINGS |
| --- | --- | --- | --- | --- | --- | --- | --- | --- | --- | --- | --- | --- | --- | --- | --- | --- | --- |
|  | 5 | **External Works** |  |  | 2017-08-10 | 2017-08-20 |  |  |  |  |  |  |  |  |  |  |  |
| CON-Z3-AS-05-EXT-010 |  | Installation of Building Signage |  | 8d | 2017-08-10 | 2017-08-20 | CON-Z3-AS-05-EW-0060 | 58.8d | 8d | Shuttering Carpenter [26 h]; Common Labor / Helper [52 h] | 822.84 | 1.3.8.50 | CONS | CONS | ZONE-3 | REALM | Art S-5 |
|  | 6 | **Testing and Precommissioning** |  |  | 2017-06-25 | 2017-08-29 |  |  |  |  |  |  |  |  |  |  |  |
| CON-Z3-AS-05-TC-0020 |  | Testing and Precommissioning of Mechanical Work |  | 12d | 2017-06-25 | 2017-07-13 | CON-Z3-AS-05-ME-0050 | 90.8d | 40d | Mechanical Technician [78 h]; Common Labor / Helper [26 h]; HVAC Crew [26 h] | 822.84 | 1.3.8.50 | CONS | CONS | ZONE-3 | REALM | Art S-5 |
| CON-Z3-AS-05-TC-0010 |  | Testing and Precommissioning of Plumbing Work |  | 12d | 2017-07-11 | 2017-07-25 | CON-Z3-AS-05-ME-0030, CON-Z3-AS-05-ME-0010 | 80.8d | 30d | Plumber [78 h]; Common Labor / Helper [52 h] | 2,057.1 | 1.3.8.50 | CONS | CONS | ZONE-3 | REALM | Art S-5 |
| CON-Z3-AS-05-TC-0030 |  | Testing and Precommissioning of Electrical Work |  | 16d | 2017-08-10 | 2017-08-29 | CON-Z3-AS-05-EW-0060 | 50.8d | 0d | Electrician [78 h]; Common Labor / Helper [26 h] | 1,234.26 | 1.3.8.50 | CONS | CONS | ZONE-3 | REALM | Art S-5 |
| CON-Z3-AS-05-TC-0040 |  | Finish of Art Works Shelter # 05 | milestone | 0d | 2017-08-29 | 2017-08-29 | CON-Z3-AS-05-TC-0020, CON-Z3-AS-05-TC-0030, CON-Z3-AS-05-TC-0010, CON-Z3-AS-05-AR-0040, CON-Z3-AS-05-EXT-010 | 50.8d | 50.6d |  |  | 1.3.8.50 | CONS | CONS | ZONE-3 | REALM | Art S-5 |
|  | 5 | **Art Works Shelter # 06** |  |  | 2017-04-22 | 2017-09-14 |  |  |  |  |  |  |  |  |  |  |  |
|  | 1 | **Civil / Structural Works** |  |  | 2017-04-22 | 2017-05-21 |  |  |  |  |  |  |  |  |  |  |  |
| CON-Z3-FS-07-CW-180 |  | Start of Art Works Shelter # 06 | milestone | 0d | 2017-04-22 | 2017-04-22 | CON-Z3-AS-05-CW-0010 FS+10d | 20.8d | 0d |  |  | 1.3.8.50 | CONS | CONS | ZONE-3 | REALM | Art S-6 |
| CON-Z3-FS-07-CW-190 |  | General Backfilling |  | 10d | 2017-04-22 | 2017-05-03 | CON-Z3-FS-07-CW-180 | 40.8d | 0d | Common Labor / Helper [78 h]; Operator - Loader [26 h]; Driver - Dump Truck [26 h]; Operator - Bobcat [26 h]; Operator - Roller-Compactor (2~10 Ton) [26 h]; Operator - Roller (25 Ton) [26 h]; Driver - Water Tanker [26 h]; Loader [28 h]; Dump Truck [28 h]; Bobcat [28 h]; Roller-Compactor (2~10 Ton) [28 h]; Roller-Compactor (25 Ton) [28 h]; Water Tanker [28 h] | 1,316.55 | 1.3.8.50 | CONS | CONS | ZONE-3 | REALM | Art S-6 |
| CON-Z3-FS-07-CW-200 |  | Installation of Slab on Garde |  | 15d | 2017-05-03 | 2017-05-21 | CON-Z3-FS-07-CW-190 | 40.8d | 0d | Steel Fixer [52 h]; Shuttering Carpenter [78 h]; Concrete Mason [78 h]; Common Labor / Helper [78 h] | 1,974.82 | 1.3.8.50 | CONS | CONS | ZONE-3 | REALM | Art S-6 |
|  | 2 | **Architectural & Finishes** |  |  | 2017-05-21 | 2017-07-17 |  |  |  |  |  |  |  |  |  |  |  |
| CON-Z3-FS-07-AR-240 |  | Plastering Work Internal and External |  | 10d | 2017-05-21 | 2017-06-01 | CON-Z3-FS-07-CW-200 | 40.8d | 0d | Concrete Mason [78 h]; Common Labor / Helper [26 h]; Scaffolder [26 h]; Finishing Work Crew [52 h] | 822.84 | 1.3.8.50 | CONS | CONS | ZONE-3 | REALM | Art S-6 |
| CON-Z3-FS-07-AR-250 |  | Installation of Concrete Topping and Floor Finishes |  | 10d | 2017-06-01 | 2017-06-13 | CON-Z3-FS-07-AR-240 | 87.8d | 0d | Common Labor / Helper [52 h]; Finishing Work Crew [52 h] | 1,097.12 | 1.3.8.50 | CONS | CONS | ZONE-3 | REALM | Art S-6 |
| CON-Z3-FS-07-AR-260 |  | Installation of Wooden Roof Trellis and other Wood Works |  | 10d | 2017-06-13 | 2017-06-25 | CON-Z3-FS-07-AR-250 | 87.8d | 0d | Shuttering Carpenter [52 h]; Common Labor / Helper [78 h]; Scaffolder [52 h]; Wood Works Crew [52 h] | 2,194.24 | 1.3.8.50 | CONS | CONS | ZONE-3 | REALM | Art S-6 |
| CON-Z3-FS-07-AR-270 |  | Painting Work Internal and External |  | 15d | 2017-06-25 | 2017-07-17 | CON-Z3-FS-07-AR-260, CON-Z3-FS-07-ME-300 FF+5d | 87.8d | 47d | Common Labor / Helper [26 h]; Scaffolder [52 h]; Painter [78 h] | 1,371.4 | 1.3.8.50 | CONS | CONS | ZONE-3 | REALM | Art S-6 |
|  | 3 | **Mechanical Works** |  |  | 2017-06-01 | 2017-07-23 |  |  |  |  |  |  |  |  |  |  |  |
| CON-Z3-FS-07-ME-300 |  | Installation of Potable Water Supply System |  | 10d | 2017-06-01 | 2017-06-13 | CON-Z3-FS-07-AR-240 | 40.8d | 0d | Plumber [300 h]; Common Labor / Helper [200 h] | 4,114.21 | 1.3.8.50 | CONS | CONS | ZONE-3 | REALM | Art S-6 |
| CON-Z3-FS-07-ME-310 |  | Installation of Free Standing Sink with drain |  | 5d | 2017-06-13 | 2017-06-19 | CON-Z3-FS-07-ME-300 | 70.8d | 0d | Plumber [130 h]; Common Labor / Helper [100 h] | 1,234.26 | 1.3.8.50 | CONS | CONS | ZONE-3 | REALM | Art S-6 |
| CON-Z3-FS-07-ME-330 |  | Installation of Drinking Fountain and BBQ Grill |  | 10d | 2017-06-19 | 2017-07-05 | CON-Z3-FS-07-ME-310 | 70.8d | 0d | Plumber [300 h]; Common Labor / Helper [200 h] | 822.84 | 1.3.8.50 | CONS | CONS | ZONE-3 | REALM | Art S-6 |
| CON-Z3-FS-07-ME-340 |  | Installation of Fire Extinguisher |  | 5d | 2017-07-05 | 2017-07-11 | CON-Z3-FS-07-ME-330 | 70.8d | 0d | Common Labor / Helper [52 h] | 822.84 | 1.3.8.50 | CONS | CONS | ZONE-3 | REALM | Art S-6 |
| CON-Z3-FS-07-ME-320 |  | Instalaltion of Tie in Connection for Water Supply system |  | 10d | 2017-07-11 | 2017-07-23 | CON-Z3-FS-07-ME-300, CON-Z3-FS-07-ME-340 | 70.8d | 0d | Plumber [52 h]; Common Labor / Helper [52 h] | 1,234.26 | 1.3.8.50 | CONS | CONS | ZONE-3 | REALM | Art S-6 |
|  | 4 | **Electrical Works** |  |  | 2017-06-13 | 2017-08-22 |  |  |  |  |  |  |  |  |  |  |  |
| CON-Z3-FS-07-EW-300 |  | Instalaltion of Conduits |  | 10d | 2017-06-13 | 2017-06-25 | CON-Z3-FS-07-ME-300 | 40.8d | 0d | Electrician [650 h]; LC Crew [130 h] | 548.56 | 1.3.8.50 | CONS | CONS | ZONE-3 | REALM | Art S-6 |
| CON-Z3-FS-07-EW-310 |  | Installation of Cables |  | 10d | 2017-06-25 | 2017-07-11 | CON-Z3-FS-07-EW-300 | 40.8d | 0d | Electrician [780 h]; LC Crew [260 h] | 1,097.12 | 1.3.8.50 | CONS | CONS | ZONE-3 | REALM | Art S-6 |
| CON-Z3-FS-07-EW-320 |  | Installation of Junction Boxes |  | 8d | 2017-07-11 | 2017-07-20 | CON-Z3-FS-07-EW-310 | 40.8d | 0d | Electrician [78 h]; LC Crew [52 h] | 548.56 | 1.3.8.50 | CONS | CONS | ZONE-3 | REALM | Art S-6 |
| CON-Z3-FS-07-EW-330 |  | Installation of receptacle outlets and wiring devices |  | 12d | 2017-07-20 | 2017-08-03 | CON-Z3-FS-07-EW-320 | 40.8d | 0d | Electrician [78 h]; LC Crew [52 h] | 1,919.96 | 1.3.8.50 | CONS | CONS | ZONE-3 | REALM | Art S-6 |
| CON-Z3-FS-07-EW-340 |  | Installation of Internal and External Lighting Fixures |  | 16d | 2017-08-03 | 2017-08-22 | CON-Z3-FS-07-EW-330 | 40.8d | 0d | Electrician [78 h]; LC Crew [52 h] | 1,371.4 | 1.3.8.50 | CONS | CONS | ZONE-3 | REALM | Art S-6 |

Notes:
- CON-Z3-AS-05-EXT-010: Expenses: (New Expense Item) 822.84
- CON-Z3-AS-05-TC-0020: Expenses: (New Expense Item) 822.84
- CON-Z3-AS-05-TC-0010: Expenses: (New Expense Item) 2057.1
- CON-Z3-AS-05-TC-0030: Expenses: (New Expense Item) 1234.26
- CON-Z3-FS-07-CW-190: Expenses: (New Expense Item) 1316.55
- CON-Z3-FS-07-CW-200: Expenses: (New Expense Item) 1974.82
- CON-Z3-FS-07-AR-240: Expenses: (New Expense Item) 822.84
- CON-Z3-FS-07-AR-250: Expenses: (New Expense Item) 1097.12
- CON-Z3-FS-07-AR-260: Expenses: (New Expense Item) 2194.24
- CON-Z3-FS-07-AR-270: Expenses: (New Expense Item) 1371.4
- CON-Z3-FS-07-ME-300: Expenses: (New Expense Item) 4114.21
- CON-Z3-FS-07-ME-310: Expenses: (New Expense Item) 1234.26
- CON-Z3-FS-07-ME-330: Expenses: (New Expense Item) 822.84
- CON-Z3-FS-07-ME-340: Expenses: (New Expense Item) 822.84
- CON-Z3-FS-07-ME-320: Expenses: (New Expense Item) 1234.26
- CON-Z3-FS-07-EW-300: Expenses: (New Expense Item) 548.56
- CON-Z3-FS-07-EW-310: Expenses: (New Expense Item) 1097.12
- CON-Z3-FS-07-EW-320: Expenses: (New Expense Item) 548.56
- CON-Z3-FS-07-EW-330: Expenses: (New Expense Item) 1919.96
- CON-Z3-FS-07-EW-340: Expenses: (New Expense Item) 1371.4

| ID | WBS | Activity | Type | Duration | Start | Finish | Predecessors | Total float | Free float | Resources | Cost | RPI_P2 - BOQ ITEMS | RPI_P2 - CONSTRUCTION | RPI_P2 - PHASE | RPI_P2 - ZONES | RPI_P2 - AREAS | RPI_P2 - BUILDINGS |
| --- | --- | --- | --- | --- | --- | --- | --- | --- | --- | --- | --- | --- | --- | --- | --- | --- | --- |
|  | 5 | **External Works** |  |  | 2017-08-22 | 2017-09-05 |  |  |  |  |  |  |  |  |  |  |  |
| CON-Z3-FS-07-EXT-60 |  | Installation of Building Signage |  | 8d | 2017-08-22 | 2017-09-05 | CON-Z3-FS-07-EW-340 | 48.8d | 8d | Shuttering Carpenter [26 h]; Common Labor / Helper [52 h] | 822.84 | 1.3.8.50 | CONS | CONS | ZONE-3 | REALM | Art S-6 |
|  | 6 | **Testing and Precommissioning** |  |  | 2017-07-11 | 2017-09-14 |  |  |  |  |  |  |  |  |  |  |  |
| CON-Z3-FS-07-TC-250 |  | Testing and Precommissioning of Mechanical Work |  | 12d | 2017-07-11 | 2017-07-25 | CON-Z3-FS-07-ME-340 | 80.8d | 40d | Mechanical Technician [78 h]; Common Labor / Helper [26 h]; HVAC Crew [26 h] | 822.84 | 1.3.8.50 | CONS | CONS | ZONE-3 | REALM | Art S-6 |
| CON-Z3-FS-07-TC-240 |  | Testing and Precommissioning of Plumbing Work |  | 12d | 2017-07-23 | 2017-08-06 | CON-Z3-FS-07-ME-320, CON-Z3-FS-07-ME-300 | 70.8d | 30d | Plumber [78 h]; Common Labor / Helper [52 h] | 2,057.1 | 1.3.8.50 | CONS | CONS | ZONE-3 | REALM | Art S-6 |
| CON-Z3-FS-07-TC-260 |  | Testing and Precommissioning of Electrical Work |  | 16d | 2017-08-22 | 2017-09-14 | CON-Z3-FS-07-EW-340 | 40.8d | 0d | Electrician [78 h]; Common Labor / Helper [26 h] | 1,234.26 | 1.3.8.50 | CONS | CONS | ZONE-3 | REALM | Art S-6 |
| CON-Z3-FS-07-TC-270 |  | Finish of Art Works Shelter # 06 | milestone | 0d | 2017-09-14 | 2017-09-14 | CON-Z3-FS-07-TC-250, CON-Z3-FS-07-EXT-60, CON-Z3-FS-07-TC-240, CON-Z3-FS-07-AR-270, CON-Z3-FS-07-TC-260 | 40.8d | 40.6d |  |  | 1.3.8.50 | CONS | CONS | ZONE-3 | REALM | Art S-6 |
|  | 6 | **Art Works Shelter # 07** |  |  | 2017-05-03 | 2017-09-27 |  |  |  |  |  |  |  |  |  |  |  |
|  | 1 | **Civil / Structural Works** |  |  | 2017-05-03 | 2017-06-01 |  |  |  |  |  |  |  |  |  |  |  |
| CON-Z3-FS-07-CW-210 |  | Start of Art Works Shelter # 07 | milestone | 0d | 2017-05-03 | 2017-05-03 | CON-Z3-FS-07-CW-180 FS+10d | 20.8d | 0d |  |  | 1.3.8.50 | CONS | CONS | ZONE-3 | REALM | Art S-7 |
| CON-Z3-FS-07-CW-220 |  | General Backfilling |  | 10d | 2017-05-03 | 2017-05-15 | CON-Z3-FS-07-CW-210 | 30.8d | 0d | Common Labor / Helper [78 h]; Operator - Loader [26 h]; Driver - Dump Truck [26 h]; Operator - Bobcat [26 h]; Operator - Roller-Compactor (2~10 Ton) [26 h]; Operator - Roller (25 Ton) [26 h]; Driver - Water Tanker [26 h]; Loader [28 h]; Dump Truck [28 h]; Bobcat [28 h]; Roller-Compactor (2~10 Ton) [28 h]; Roller-Compactor (25 Ton) [28 h]; Water Tanker [28 h] | 1,316.55 | 1.3.8.50 | CONS | CONS | ZONE-3 | REALM | Art S-7 |
| CON-Z3-FS-07-CW-230 |  | Installation of Slab on Garde |  | 15d | 2017-05-15 | 2017-06-01 | CON-Z3-FS-07-CW-220 | 30.8d | 0d | Steel Fixer [52 h]; Shuttering Carpenter [78 h]; Concrete Mason [78 h]; Common Labor / Helper [78 h] | 1,974.82 | 1.3.8.50 | CONS | CONS | ZONE-3 | REALM | Art S-7 |
|  | 2 | **Architectural & Finishes** |  |  | 2017-06-01 | 2017-07-29 |  |  |  |  |  |  |  |  |  |  |  |
| CON-Z3-FS-07-AR-280 |  | Plastering Work Internal and External |  | 10d | 2017-06-01 | 2017-06-13 | CON-Z3-FS-07-CW-230 | 30.8d | 0d | Concrete Mason [300 h]; Common Labor / Helper [200 h]; Scaffolder [300 h]; Finishing Work Crew [130 h] | 822.84 | 1.3.8.50 | CONS | CONS | ZONE-3 | REALM | Art S-7 |
| CON-Z3-FS-07-AR-290 |  | Installation of Concrete Topping and Floor Finishes |  | 10d | 2017-06-13 | 2017-06-25 | CON-Z3-FS-07-AR-280 | 77.8d | 0d | Common Labor / Helper [780 h]; Finishing Work Crew [130 h]; Concrete Mason [780 h] | 1,097.12 | 1.3.8.50 | CONS | CONS | ZONE-3 | REALM | Art S-7 |
| CON-Z3-FS-07-AR-300 |  | Installation of Wooden Roof Trellis and other Wood Works |  | 10d | 2017-06-25 | 2017-07-11 | CON-Z3-FS-07-AR-290 | 77.8d | 0d | Shuttering Carpenter [520 h]; Common Labor / Helper [780 h]; Scaffolder [390 h]; Wood Works Crew [260 h] | 2,194.24 | 1.3.8.50 | CONS | CONS | ZONE-3 | REALM | Art S-7 |
| CON-Z3-FS-07-AR-310 |  | Painting Work Internal and External |  | 15d | 2017-07-11 | 2017-07-29 | CON-Z3-FS-07-AR-300, CON-Z3-FS-07-ME-350 FF+5d | 77.8d | 47d | Common Labor / Helper [26 h]; Scaffolder [52 h]; Painter [78 h] | 1,371.4 | 1.3.8.50 | CONS | CONS | ZONE-3 | REALM | Art S-7 |
|  | 3 | **Mechanical Works** |  |  | 2017-06-13 | 2017-08-03 |  |  |  |  |  |  |  |  |  |  |  |
| CON-Z3-FS-07-ME-350 |  | Installation of Potable Water Supply System |  | 10d | 2017-06-13 | 2017-06-25 | CON-Z3-FS-07-AR-280 | 30.8d | 0d | Plumber [300 h]; Common Labor / Helper [200 h] | 4,114.21 | 1.3.8.50 | CONS | CONS | ZONE-3 | REALM | Art S-7 |
| CON-Z3-FS-07-ME-360 |  | Installation of Free Standing Sink with drain |  | 5d | 2017-06-25 | 2017-07-05 | CON-Z3-FS-07-ME-350 | 60.8d | 0d | Plumber [150 h]; Common Labor / Helper [100 h] | 1,234.26 | 1.3.8.50 | CONS | CONS | ZONE-3 | REALM | Art S-7 |
| CON-Z3-FS-07-ME-380 |  | Installation of Drinking Fountain and BBQ Grill |  | 10d | 2017-07-05 | 2017-07-17 | CON-Z3-FS-07-ME-360 | 60.8d | 0d | Plumber [26 h]; Common Labor / Helper [52 h] | 822.84 | 1.3.8.50 | CONS | CONS | ZONE-3 | REALM | Art S-7 |
| CON-Z3-FS-07-ME-390 |  | Installation of Fire Extinguisher |  | 5d | 2017-07-17 | 2017-07-23 | CON-Z3-FS-07-ME-380 | 60.8d | 0d | Common Labor / Helper [52 h] | 822.84 | 1.3.8.50 | CONS | CONS | ZONE-3 | REALM | Art S-7 |
| CON-Z3-FS-07-ME-370 |  | Instalaltion of Tie in Connection for Water Supply system |  | 10d | 2017-07-23 | 2017-08-03 | CON-Z3-FS-07-ME-350, CON-Z3-FS-07-ME-390 | 60.8d | 0d | Plumber [52 h]; Common Labor / Helper [52 h] | 1,234.26 | 1.3.8.50 | CONS | CONS | ZONE-3 | REALM | Art S-7 |
|  | 4 | **Electrical Works** |  |  | 2017-06-25 | 2017-09-07 |  |  |  |  |  |  |  |  |  |  |  |
| CON-Z3-FS-07-EW-350 |  | Instalaltion of Conduits |  | 10d | 2017-06-25 | 2017-07-11 | CON-Z3-FS-07-ME-350 | 30.8d | 0d | Electrician [780 h]; LC Crew [260 h] | 548.56 | 1.3.8.50 | CONS | CONS | ZONE-3 | REALM | Art S-7 |
| CON-Z3-FS-07-EW-360 |  | Installation of Cables |  | 10d | 2017-07-11 | 2017-07-23 | CON-Z3-FS-07-EW-350 | 30.8d | 0d | Electrician [78 h]; LC Crew [52 h] | 1,097.12 | 1.3.8.50 | CONS | CONS | ZONE-3 | REALM | Art S-7 |
| CON-Z3-FS-07-EW-370 |  | Installation of Junction Boxes |  | 8d | 2017-07-23 | 2017-08-01 | CON-Z3-FS-07-EW-360 | 30.8d | 0d | Electrician [78 h]; LC Crew [52 h] | 548.56 | 1.3.8.50 | CONS | CONS | ZONE-3 | REALM | Art S-7 |
| CON-Z3-FS-07-EW-380 |  | Installation of receptacle outlets and wiring devices |  | 12d | 2017-08-01 | 2017-08-15 | CON-Z3-FS-07-EW-370 | 30.8d | 0d | Electrician [78 h]; LC Crew [52 h] | 1,919.96 | 1.3.8.50 | CONS | CONS | ZONE-3 | REALM | Art S-7 |
| CON-Z3-FS-07-EW-390 |  | Installation of Internal and External Lighting Fixures |  | 16d | 2017-08-15 | 2017-09-07 | CON-Z3-FS-07-EW-380 | 30.8d | 0d | Electrician [78 h]; LC Crew [52 h] | 1,371.4 | 1.3.8.50 | CONS | CONS | ZONE-3 | REALM | Art S-7 |

Notes:
- CON-Z3-FS-07-EXT-60: Expenses: (New Expense Item) 822.84
- CON-Z3-FS-07-TC-250: Expenses: (New Expense Item) 822.84
- CON-Z3-FS-07-TC-240: Expenses: (New Expense Item) 2057.1
- CON-Z3-FS-07-TC-260: Expenses: (New Expense Item) 1234.26
- CON-Z3-FS-07-CW-220: Expenses: (New Expense Item) 1316.55
- CON-Z3-FS-07-CW-230: Expenses: (New Expense Item) 1974.82
- CON-Z3-FS-07-AR-280: Expenses: (New Expense Item) 822.84
- CON-Z3-FS-07-AR-290: Expenses: (New Expense Item) 1097.12
- CON-Z3-FS-07-AR-300: Expenses: (New Expense Item) 2194.24
- CON-Z3-FS-07-AR-310: Expenses: (New Expense Item) 1371.4
- CON-Z3-FS-07-ME-350: Expenses: (New Expense Item) 4114.21
- CON-Z3-FS-07-ME-360: Expenses: (New Expense Item) 1234.26
- CON-Z3-FS-07-ME-380: Expenses: (New Expense Item) 822.84
- CON-Z3-FS-07-ME-390: Expenses: (New Expense Item) 822.84
- CON-Z3-FS-07-ME-370: Expenses: (New Expense Item) 1234.26
- CON-Z3-FS-07-EW-350: Expenses: (New Expense Item) 548.56
- CON-Z3-FS-07-EW-360: Expenses: (New Expense Item) 1097.12
- CON-Z3-FS-07-EW-370: Expenses: (New Expense Item) 548.56
- CON-Z3-FS-07-EW-380: Expenses: (New Expense Item) 1919.96
- CON-Z3-FS-07-EW-390: Expenses: (New Expense Item) 1371.4

| ID | WBS | Activity | Type | Duration | Start | Finish | Predecessors | Total float | Free float | Resources | Cost | RPI_P2 - BOQ ITEMS | RPI_P2 - CONSTRUCTION | RPI_P2 - PHASE | RPI_P2 - ZONES | RPI_P2 - AREAS | RPI_P2 - BUILDINGS |
| --- | --- | --- | --- | --- | --- | --- | --- | --- | --- | --- | --- | --- | --- | --- | --- | --- | --- |
|  | 5 | **External Works** |  |  | 2017-09-07 | 2017-09-17 |  |  |  |  |  |  |  |  |  |  |  |
| CON-Z3-FS-07-EXT-70 |  | Installation of Building Signage |  | 8d | 2017-09-07 | 2017-09-17 | CON-Z3-FS-07-EW-390 | 38.8d | 8d | Shuttering Carpenter [26 h]; Common Labor / Helper [52 h] | 822.84 | 1.3.8.50 | CONS | CONS | ZONE-3 | REALM | Art S-7 |
|  | 6 | **Testing and Precommissioning** |  |  | 2017-07-23 | 2017-09-27 |  |  |  |  |  |  |  |  |  |  |  |
| CON-Z3-FS-07-TC-290 |  | Testing and Precommissioning of Mechanical Work |  | 12d | 2017-07-23 | 2017-08-06 | CON-Z3-FS-07-ME-390 | 70.8d | 40d | Mechanical Technician [78 h]; Common Labor / Helper [26 h]; HVAC Crew [26 h] | 822.84 | 1.3.8.50 | CONS | CONS | ZONE-3 | REALM | Art S-7 |
| CON-Z3-FS-07-TC-280 |  | Testing and Precommissioning of Plumbing Work |  | 12d | 2017-08-03 | 2017-08-17 | CON-Z3-FS-07-ME-350, CON-Z3-FS-07-ME-370 | 60.8d | 30d | Plumber [78 h]; Common Labor / Helper [52 h] | 2,057.1 | 1.3.8.50 | CONS | CONS | ZONE-3 | REALM | Art S-7 |
| CON-Z3-FS-07-TC-300 |  | Testing and Precommissioning of Electrical Work |  | 16d | 2017-09-07 | 2017-09-27 | CON-Z3-FS-07-EW-390 | 30.8d | 0d | Electrician [78 h]; Common Labor / Helper [26 h] | 1,234.26 | 1.3.8.50 | CONS | CONS | ZONE-3 | REALM | Art S-7 |
| CON-Z3-FS-07-TC-310 |  | Finish of Art Works Shelter # 07 | milestone | 0d | 2017-09-27 | 2017-09-27 | CON-Z3-FS-07-TC-280, CON-Z3-FS-07-TC-290, CON-Z3-FS-07-TC-300, CON-Z3-FS-07-EXT-70, CON-Z3-FS-07-AR-310 | 30.8d | 30.6d |  |  | 1.3.8.50 | CONS | CONS | ZONE-3 | REALM | Art S-7 |
|  | 7 | **Art Works Shelter # 08** |  |  | 2017-05-15 | 2017-10-09 |  |  |  |  |  |  |  |  |  |  |  |
|  | 1 | **Civil / Structural Works** |  |  | 2017-05-15 | 2017-06-13 |  |  |  |  |  |  |  |  |  |  |  |
| CON-Z3-FS-08-CW-240 |  | Start of Art Works Shelter # 08 | milestone | 0d | 2017-05-15 | 2017-05-15 | CON-Z3-FS-07-CW-210 FS+10d | 20.8d | 0d |  |  | 1.3.8.50 | CONS | CONS | ZONE-3 | REALM | Art S-8 |
| CON-Z3-FS-08-CW-250 |  | General Backfilling |  | 10d | 2017-05-15 | 2017-05-27 | CON-Z3-FS-08-CW-240 | 20.8d | 0d | Common Labor / Helper [78 h]; Operator - Loader [26 h]; Driver - Dump Truck [26 h]; Operator - Bobcat [26 h]; Operator - Roller-Compactor (2~10 Ton) [26 h]; Operator - Roller (25 Ton) [26 h]; Driver - Water Tanker [26 h]; Loader [28 h]; Dump Truck [28 h]; Bobcat [28 h]; Roller-Compactor (2~10 Ton) [28 h]; Roller-Compactor (25 Ton) [28 h]; Water Tanker [28 h] | 1,316.55 | 1.3.8.50 | CONS | CONS | ZONE-3 | REALM | Art S-8 |
| CON-Z3-FS-08-CW-260 |  | Installation of Slab on Garde |  | 15d | 2017-05-27 | 2017-06-13 | CON-Z3-FS-08-CW-250 | 20.8d | 0d | Steel Fixer [52 h]; Shuttering Carpenter [78 h]; Concrete Mason [78 h]; Common Labor / Helper [78 h] | 1,974.82 | 1.3.8.50 | CONS | CONS | ZONE-3 | REALM | Art S-8 |
|  | 2 | **Architectural & Finishes** |  |  | 2017-06-13 | 2017-08-09 |  |  |  |  |  |  |  |  |  |  |  |
| CON-Z3-FS-08-AR-320 |  | Plastering Work Internal and External |  | 10d | 2017-06-13 | 2017-06-25 | CON-Z3-FS-08-CW-260 | 20.8d | 0d | Concrete Mason [200 h]; Common Labor / Helper [100 h]; Scaffolder [100 h]; Finishing Work Crew [100 h] | 822.84 | 1.3.8.50 | CONS | CONS | ZONE-3 | REALM | Art S-8 |
| CON-Z3-FS-08-AR-330 |  | Installation of Concrete Topping and Floor Finishes |  | 10d | 2017-06-25 | 2017-07-11 | CON-Z3-FS-08-AR-320 | 67.8d | 0d | Common Labor / Helper [200 h]; Finishing Work Crew [130 h]; Concrete Mason [200 h] | 1,097.12 | 1.3.8.50 | CONS | CONS | ZONE-3 | REALM | Art S-8 |
| CON-Z3-FS-08-AR-340 |  | Installation of Wooden Roof Trellis and other Wood Works |  | 10d | 2017-07-11 | 2017-07-23 | CON-Z3-FS-08-AR-330 | 67.8d | 0d | Shuttering Carpenter [52 h]; Common Labor / Helper [78 h]; Scaffolder [52 h]; Wood Works Crew [52 h] | 2,194.24 | 1.3.8.50 | CONS | CONS | ZONE-3 | REALM | Art S-8 |
| CON-Z3-FS-08-AR-350 |  | Painting Work Internal and External |  | 15d | 2017-07-23 | 2017-08-09 | CON-Z3-FS-08-ME-400 FF+5d, CON-Z3-FS-08-AR-340 | 67.8d | 47d | Common Labor / Helper [26 h]; Scaffolder [52 h]; Painter [78 h] | 1,371.4 | 1.3.8.50 | CONS | CONS | ZONE-3 | REALM | Art S-8 |
|  | 3 | **Mechanical Works** |  |  | 2017-06-25 | 2017-08-15 |  |  |  |  |  |  |  |  |  |  |  |
| CON-Z3-FS-08-ME-400 |  | Installation of Potable Water Supply System |  | 10d | 2017-06-25 | 2017-07-11 | CON-Z3-FS-08-AR-320 | 20.8d | 0d | Plumber [300 h]; Common Labor / Helper [200 h] | 4,114.21 | 1.3.8.50 | CONS | CONS | ZONE-3 | REALM | Art S-8 |
| CON-Z3-FS-08-ME-410 |  | Installation of Free Standing Sink with drain |  | 5d | 2017-07-11 | 2017-07-17 | CON-Z3-FS-08-ME-400 | 50.8d | 0d | Plumber [26 h]; Common Labor / Helper [52 h] | 1,234.26 | 1.3.8.50 | CONS | CONS | ZONE-3 | REALM | Art S-8 |
| CON-Z3-FS-08-ME-430 |  | Installation of Drinking Fountain and BBQ Grill |  | 10d | 2017-07-17 | 2017-07-29 | CON-Z3-FS-08-ME-410 | 50.8d | 0d | Plumber [26 h]; Common Labor / Helper [52 h] | 822.84 | 1.3.8.50 | CONS | CONS | ZONE-3 | REALM | Art S-8 |
| CON-Z3-FS-08-ME-440 |  | Installation of Fire Extinguisher |  | 5d | 2017-07-29 | 2017-08-03 | CON-Z3-FS-08-ME-430 | 50.8d | 0d | Common Labor / Helper [52 h] | 822.84 | 1.3.8.50 | CONS | CONS | ZONE-3 | REALM | Art S-8 |
| CON-Z3-FS-08-ME-420 |  | Instalaltion of Tie in Connection for Water Supply system |  | 10d | 2017-08-03 | 2017-08-15 | CON-Z3-FS-08-ME-400, CON-Z3-FS-08-ME-440 | 50.8d | 0d | Plumber [52 h]; Common Labor / Helper [52 h] | 1,234.26 | 1.3.8.50 | CONS | CONS | ZONE-3 | REALM | Art S-8 |
|  | 4 | **Electrical Works** |  |  | 2017-07-11 | 2017-09-19 |  |  |  |  |  |  |  |  |  |  |  |
| CON-Z3-FS-08-EW-400 |  | Instalaltion of Conduits |  | 10d | 2017-07-11 | 2017-07-23 | CON-Z3-FS-08-ME-400 | 20.8d | 0d | Electrician [78 h]; LC Crew [52 h] | 548.56 | 1.3.8.50 | CONS | CONS | ZONE-3 | REALM | Art S-8 |
| CON-Z3-FS-08-EW-410 |  | Installation of Cables |  | 10d | 2017-07-23 | 2017-08-03 | CON-Z3-FS-08-EW-400 | 20.8d | 0d | Electrician [78 h]; LC Crew [52 h] | 1,097.12 | 1.3.8.50 | CONS | CONS | ZONE-3 | REALM | Art S-8 |
| CON-Z3-FS-08-EW-420 |  | Installation of Junction Boxes |  | 8d | 2017-08-03 | 2017-08-13 | CON-Z3-FS-08-EW-410 | 20.8d | 0d | Electrician [78 h]; LC Crew [52 h] | 548.56 | 1.3.8.50 | CONS | CONS | ZONE-3 | REALM | Art S-8 |
| CON-Z3-FS-08-EW-430 |  | Installation of receptacle outlets and wiring devices |  | 12d | 2017-08-13 | 2017-08-27 | CON-Z3-FS-08-EW-420 | 20.8d | 0d | Electrician [78 h]; LC Crew [52 h] | 1,919.96 | 1.3.8.50 | CONS | CONS | ZONE-3 | REALM | Art S-8 |
| CON-Z3-FS-08-EW-440 |  | Installation of Internal and External Lighting Fixures |  | 16d | 2017-08-27 | 2017-09-19 | CON-Z3-FS-08-EW-430 | 20.8d | 0d | Electrician [78 h]; LC Crew [52 h] | 1,371.4 | 1.3.8.50 | CONS | CONS | ZONE-3 | REALM | Art S-8 |

Notes:
- CON-Z3-FS-07-EXT-70: Expenses: (New Expense Item) 822.84
- CON-Z3-FS-07-TC-290: Expenses: (New Expense Item) 822.84
- CON-Z3-FS-07-TC-280: Expenses: (New Expense Item) 2057.1
- CON-Z3-FS-07-TC-300: Expenses: (New Expense Item) 1234.26
- CON-Z3-FS-08-CW-250: Expenses: (New Expense Item) 1316.55
- CON-Z3-FS-08-CW-260: Expenses: (New Expense Item) 1974.82
- CON-Z3-FS-08-AR-320: Expenses: (New Expense Item) 822.84
- CON-Z3-FS-08-AR-330: Expenses: (New Expense Item) 1097.12
- CON-Z3-FS-08-AR-340: Expenses: (New Expense Item) 2194.24
- CON-Z3-FS-08-AR-350: Expenses: (New Expense Item) 1371.4
- CON-Z3-FS-08-ME-400: Expenses: (New Expense Item) 4114.21
- CON-Z3-FS-08-ME-410: Expenses: (New Expense Item) 1234.26
- CON-Z3-FS-08-ME-430: Expenses: (New Expense Item) 822.84
- CON-Z3-FS-08-ME-440: Expenses: (New Expense Item) 822.84
- CON-Z3-FS-08-ME-420: Expenses: (New Expense Item) 1234.26
- CON-Z3-FS-08-EW-400: Expenses: (New Expense Item) 548.56
- CON-Z3-FS-08-EW-410: Expenses: (New Expense Item) 1097.12
- CON-Z3-FS-08-EW-420: Expenses: (New Expense Item) 548.56
- CON-Z3-FS-08-EW-430: Expenses: (New Expense Item) 1919.96
- CON-Z3-FS-08-EW-440: Expenses: (New Expense Item) 1371.4

| ID | WBS | Activity | Type | Duration | Start | Finish | Predecessors | Total float | Free float | Resources | Cost | RPI_P2 - BOQ ITEMS | RPI_P2 - CONSTRUCTION | RPI_P2 - PHASE | RPI_P2 - ZONES | RPI_P2 - AREAS | RPI_P2 - BUILDINGS | RPI_P2 - DISCIPLINE / WORK TYPE | RPI_P2 - UTILITY NETWORK | Wajid |
| --- | --- | --- | --- | --- | --- | --- | --- | --- | --- | --- | --- | --- | --- | --- | --- | --- | --- | --- | --- | --- |
|  | 5 | **External Works** |  |  | 2017-09-19 | 2017-09-30 |  |  |  |  |  |  |  |  |  |  |  |  |  |  |
| CON-Z3-FS-08-EXT-80 |  | Installation of Building Signage |  | 8d | 2017-09-19 | 2017-09-30 | CON-Z3-FS-08-EW-440 | 28.8d | 8d | Shuttering Carpenter [78 h]; Common Labor / Helper [52 h] | 822.84 | 1.3.8.50 | CONS | CONS | ZONE-3 | REALM | Art S-8 |  |  |  |
|  | 6 | **Testing and Precommissioning** |  |  | 2017-08-03 | 2017-10-09 |  |  |  |  |  |  |  |  |  |  |  |  |  |  |
| CON-Z3-FS-08-TC-330 |  | Testing and Precommissioning of Mechanical Work |  | 12d | 2017-08-03 | 2017-08-17 | CON-Z3-FS-08-ME-440 | 60.8d | 40d | Mechanical Technician [78 h]; Common Labor / Helper [26 h]; HVAC Crew [26 h] | 822.84 | 1.3.8.50 | CONS | CONS | ZONE-3 | REALM | Art S-8 |  |  |  |
| CON-Z3-FS-08-TC-320 |  | Testing and Precommissioning of Plumbing Work |  | 12d | 2017-08-15 | 2017-08-29 | CON-Z3-FS-08-ME-400, CON-Z3-FS-08-ME-420 | 50.8d | 30d | Plumber [78 h]; Common Labor / Helper [52 h] | 2,057.1 | 1.3.8.50 | CONS | CONS | ZONE-3 | REALM | Art S-8 |  |  |  |
| CON-Z3-FS-08-TC-340 |  | Testing and Precommissioning of Electrical Work |  | 16d | 2017-09-19 | 2017-10-09 | CON-Z3-FS-08-EW-440 | 20.8d | 0d | Electrician [78 h]; Common Labor / Helper [26 h] | 1,234.26 | 1.3.8.50 | CONS | CONS | ZONE-3 | REALM | Art S-8 |  |  |  |
| CON-Z3-FS-08-TC-350 |  | Finish of Art Works Shelter # 08 | milestone | 0d | 2017-10-09 | 2017-10-09 | CON-Z3-FS-08-AR-350, CON-Z3-FS-08-TC-330, CON-Z3-FS-08-TC-320, CON-Z3-FS-08-TC-340, CON-Z3-FS-08-EXT-80 | 20.8d | 20.6d |  |  | 1.3.8.50 | CONS | CONS | ZONE-3 | REALM | Art S-8 |  |  |  |
|  | 6 | **PRECOMMISSIONING AND DEMOBILIZATION FOR ZONE - 3 & ZONE - 4** |  |  | 2017-08-14 | 2018-01-29 |  |  |  |  |  |  |  |  |  |  |  |  |  |  |
|  | 1 | **PRE-COMMISSIONING WORKS** |  |  | 2017-08-30 | 2018-01-10 |  |  |  |  |  |  |  |  |  |  |  |  |  |  |
|  | 1 | **Approved Pre-Commissioning Plans** |  |  | 2017-09-06 | 2017-10-12 |  |  |  |  |  |  |  |  |  |  |  |  |  |  |
| CO-PD-PC-PL-GE-0010 |  | Approved Pre-Commissioning Plans |  | 30d | 2017-09-06 | 2017-10-12 | CO-PD-PC-PC-GE-0010 SS+2d | 27.8d | 0d |  | 213,476.07 | 1.3.9.10 | CONS | TC |  |  |  | GEN |  |  |
|  | 2 | **Approved Operating Spare Parts Data Package** |  |  | 2017-09-06 | 2017-10-12 |  |  |  |  |  |  |  |  |  |  |  |  |  |  |
| CO-PD-PC-SP-GE-0010 |  | Approved Operating Spare Parts Data Packages |  | 30d | 2017-09-06 | 2017-10-12 | CO-PD-PC-PL-GE-0010 SS | 27.8d | 0d |  | 213,476.07 | 1.3.9.20 | CONS | TC |  |  |  | GEN |  |  |
|  | 3 | **Approved Operation and Maintenance Manuals** |  |  | 2017-10-12 | 2017-11-16 |  |  |  |  |  |  |  |  |  |  |  |  |  |  |
| CO-PD-PC-MN-GE-0010 |  | Approved Operation and Maintenance Manuals |  | 30d | 2017-10-12 | 2017-11-16 | CO-PD-PC-SP-GE-0010 | 27.8d | 0d |  | 213,476.07 | 1.3.9.30 | CONS | TC |  |  |  | GEN |  |  |
|  | 4 | **Complete Pre-Commissioning** |  |  | 2017-08-30 | 2017-11-28 |  |  |  |  |  |  |  |  |  |  |  |  |  |  |
| CO-PD-PC-PC-GE-0010 |  | Tie in to KAUST Utilities |  | 30d | 2017-08-30 | 2017-10-10 | CON-SZ3-SEA-TIE-100, CON-Z3-UT-IRG-GE-050, CON-SZ3-SS-TIE-60, CON-Z3-UTI-RD-GE-010, CON-SZ3-SS-TIE-0040 | 27.8d | 0d | Plumber [26 h]; Welder [26 h]; Common Labor / Helper [52 h]; RTR Pipe Crew [52 h] | 139,591.47 | 1.3.9.40 | CONS | TC |  |  |  | MECH |  |  |
| CO-PD-PC-PC-GE-0020 |  | Complete Pre-Commissioning for Electrical Works |  | 60d | 2017-09-18 | 2017-11-28 | CONC-Z4-UTIL-ELE-120, CONC-Z4-UTIL-ELE-130 FS+13d | 2.8d | 0d | Electrician [104 h]; LC Crew [52 h] | 1,046,936 | 1.3.9.40 | CONS | TC |  |  |  | ELEC | POWER |  |
| CO-PD-PC-PC-GE-0030 |  | Complete Pre-Commissioning for Mechanical Works |  | 30d | 2017-10-24 | 2017-11-28 | RPI-Z3-LS10-TC-0060, CON-Z4-LS9-TC-0060, CO-PD-PC-PC-GE-0020 SS+30d, RPI-Z3-LS11-TC-0060 | 2.8d | 0d | Mechanical Technician [52 h] | 1,046,936 | 1.3.9.40 | CONS | TC |  |  |  | MECH | PW |  |
| CO-PD-PC-PC-GE-0040 |  | Complete Pre-Commissioning for Instrumentation Works |  | 25d | 2017-10-30 | 2017-11-28 | CO-PD-PC-PC-GE-0030 SS+5d | 2.8d | 0d | Electrician [78 h] | 209,387.21 | 1.3.9.40 | CONS | TC |  |  |  | MECH | SEWER |  |
| CO-PD-PC-PC-GE-0090 |  | Complete Pre-Commissioning for Communication Works |  | 15d | 2017-11-11 | 2017-11-28 | CON-Z3-UTIL-COM-1730, CON-Z4-UTIL-COM-560, CON-Z3-UTIL-COM-1620, CON-Z3-UTIL-COM-1680, CON-Z3-UTIL-COM-0460, CON-Z3-UTIL-COM-0370 FF, CON-Z3-UTIL-COM-1780, CON-Z3-UTIL-COM-1830, CON-Z3-UTIL-COM-1150, CON-Z1-UTIL-COM-360, CON-Z3-UTIL-COM-0040, CON-Z4-UTIL-COM-0400 FF, CON-Z3-UTIL-COM-1640, CON-Z3-UTIL-COM-1660, CO-PD-PC-PC-GE-0040 SS+10d | 2.8d |  | LC Crew [52 h]; Specialist Works Crew [26 h] | 1,046,936 | 1.3.9.40 | CONS | TC |  |  |  | COMM | COMM | OK |
|  | 5 | **EIL (Punch Lists)** |  |  | 2017-11-11 | 2018-01-10 |  |  |  |  |  |  |  |  |  |  |  |  |  |  |
| CO-PD-PC-PC-GE-0060 |  | EIL Closing for Zone 3 |  | 24d | 2017-11-11 | 2017-12-09 | CO-PD-PC-PC-GE-0050 FF+4d | 17.8d | 0d | Steel Fixer [260 h]; Shuttering Carpenter [260 h]; Concrete Mason [104 h]; Plumber [260 h]; Electrician [520 h]; Mechanical Technician [104 h]; Welder [104 h]; Common Labor / Helper [520 h]; Scaffolder [156 h]; Block Mason [260 h]; Plaster Mason [156 h]; Tiling Crew [104 h]; Painter [260 h]; RTR Pipe Crew [208 h]; Water Proofing Crew [156 h]; HVAC Crew [104 h]; LC Crew [156 h]; Fence Crew - Lift Station [52 h]; Wood Works Crew [104 h]; Gypsum Walls & Ceiling Crew [104 h]; Road Works Crew [156 h]; Finishing Work Crew [156 h]; Hardscape Crew [104 h]; Soft Landscaping Crew [104 h]; Specialist Works Crew [156 h] |  |  | CONS | TC |  |  |  | GEN |  |  |
| CO-PD-PC-PC-GE-0050 |  | EIL Closing for Zone 1 & 2 |  | 16d | 2017-11-15 | 2017-12-04 | CO-PD-PC-PC-GE-0040 FF+5d | 17.8d | 0d | Steel Fixer [260 h]; Shuttering Carpenter [260 h]; Concrete Mason [104 h]; Plumber [260 h]; Electrician [520 h]; Mechanical Technician [104 h]; Welder [104 h]; Common Labor / Helper [520 h]; Scaffolder [156 h]; Block Mason [260 h]; Plaster Mason [156 h]; Tiling Crew [104 h]; Painter [260 h]; RTR Pipe Crew [208 h]; Water Proofing Crew [156 h]; HVAC Crew [104 h]; LC Crew [156 h]; Fence Crew - Lift Station [52 h]; Wood Works Crew [104 h]; Gypsum Walls & Ceiling Crew [104 h]; Road Works Crew [156 h]; Finishing Work Crew [156 h]; Hardscape Crew [104 h]; Soft Landscaping Crew [104 h]; Specialist Works Crew [156 h] |  |  | CONS | TC |  |  |  | GEN |  |  |
| CO-PD-PC-PC-GE-0070 |  | EIL Closing for Zone 4 |  | 24d | 2017-12-09 | 2018-01-06 | CO-PD-PC-PC-GE-0060 | 17.8d | 0d | Steel Fixer [260 h]; Shuttering Carpenter [260 h]; Concrete Mason [104 h]; Plumber [260 h]; Electrician [520 h]; Mechanical Technician [104 h]; Welder [104 h]; Common Labor / Helper [520 h]; Scaffolder [156 h]; Block Mason [260 h]; Plaster Mason [156 h]; Tiling Crew [104 h]; Painter [260 h]; RTR Pipe Crew [208 h]; Water Proofing Crew [156 h]; HVAC Crew [104 h]; LC Crew [156 h]; Fence Crew - Lift Station [52 h]; Wood Works Crew [104 h]; Gypsum Walls & Ceiling Crew [104 h]; Road Works Crew [156 h]; Finishing Work Crew [156 h]; Hardscape Crew [104 h]; Soft Landscaping Crew [104 h]; Specialist Works Crew [156 h] |  |  | CONS | TC |  |  |  | GEN |  |  |
| CO-PD-PC-PC-GE-0080 |  | Issuance of MCAN Certificate |  | 4d | 2018-01-06 | 2018-01-10 | CO-PD-PC-PC-GE-0070 | 17.8d |  |  |  |  | CONS | TC |  |  |  | GEN |  |  |

Notes:
- CON-Z3-FS-08-EXT-80: Expenses: (New Expense Item) 822.84
- CON-Z3-FS-08-TC-330: Expenses: (New Expense Item) 822.84
- CON-Z3-FS-08-TC-320: Expenses: (New Expense Item) 2057.1
- CON-Z3-FS-08-TC-340: Expenses: (New Expense Item) 1234.26
- CO-PD-PC-PL-GE-0010: Expenses: (New Expense Item) 213476
- CO-PD-PC-SP-GE-0010: Expenses: (New Expense Item) 213476
- CO-PD-PC-MN-GE-0010: Expenses: (New Expense Item) 213476
- CO-PD-PC-PC-GE-0010: Expenses: (New Expense Item) 139591
- CO-PD-PC-PC-GE-0020: Expenses: (New Expense Item) 1046936
- CO-PD-PC-PC-GE-0030: Expenses: (New Expense Item) 1046936
- CO-PD-PC-PC-GE-0040: Expenses: (New Expense Item) 209387
- CO-PD-PC-PC-GE-0090: Expenses: (New Expense Item) 1046936

| ID | WBS | Activity | Duration | Start | Finish | Predecessors | Total float | Free float | Resources | Cost | RPI_P2 - BOQ ITEMS | RPI_P2 - CONSTRUCTION | RPI_P2 - PHASE | RPI_P2 - DISCIPLINE / WORK TYPE | Wajid |
| --- | --- | --- | --- | --- | --- | --- | --- | --- | --- | --- | --- | --- | --- | --- | --- |
|  | 2 | **DEMOBILIZATIONS** |  | 2017-08-14 | 2018-01-29 |  |  |  |  |  |  |  |  |  |  |
|  | 1 | **Complete As-Built CADD** |  | 2017-10-12 | 2017-11-16 |  |  |  |  |  |  |  |  |  |  |
| CO-PD-DM-AB-GE-0010 |  | Complete As-Built CADD Drawings | 30d | 2017-10-12 | 2017-11-16 | CO-PD-PC-MN-GE-0010 SS | 27.8d | 0d |  | 467,939.55 | 1.3.10.10 | CONS | DEMOB | GEN |  |
|  | 2 | **Approved Project Record Books** |  | 2017-10-23 | 2017-11-29 |  |  |  |  |  |  |  |  |  |  |
| CO-PD-DM-RB-GE-0010 |  | Project Record Books | 32d | 2017-10-23 | 2017-11-29 | CO-PD-DM-AB-GE-0010 SS+9d | 27.8d | 0d |  | 701,909.32 | 1.3.10.20 | CONS | DEMOB | GEN |  |
|  | 3 | **Complete Restoration of Palm Trees** |  | 2017-10-23 | 2017-11-04 |  |  |  |  |  |  |  |  |  |  |
| CO-PD-DM-PT-GE-0010 |  | Complete Restoration of Palm Trees | 10d | 2017-10-23 | 2017-11-04 | CO-PD-DM-RB-GE-0010 SS, CON-Z3-LS-PT-0030, CON-Z2-LS-PT-0010 | 75.8d |  | Common Labor / Helper [520 h] | 1,685,166.43 | 1.3.10.30 | CONS | DEMOB | CIVIL |  |
|  | 4 | **Complete Restoration of previous damages to site for all Research Park Zones** |  | 2017-08-14 | 2017-10-23 |  |  |  |  |  |  |  |  |  |  |
| CO-PD-DM-RD-GE-0010 |  | Complete Restoration of Previous damages to Site for all Research Park Zones | 56d | 2017-08-14 | 2017-10-23 | GE-GE-GE-GE-GE-0010 FS+370d | 33d |  | Common Labor / Helper [780 h] | 288,169.3 | 1.3.10.40 | CONS | DEMOB | CIVIL | OK |
|  | 5 | **Complete Jersey Barrier Removal for all Research Park Zones** |  | 2017-11-01 | 2017-12-31 |  |  |  |  |  |  |  |  |  |  |
| CO-PD-DM-JB-GE-0010 |  | Complete Jersey Barrier Removal from Zone-2, 3 & 4 (10.2 KM) | 52d | 2017-11-01 | 2017-12-31 | GE-GE-GE-GE-GE-0010 FS+449d | 26d | 0d | Common Labor / Helper [33800 h]; Operator - Mobile Crane [4056 h]; Driver - Flat Bed Trailer [4056 h]; Mobile Crane ( 25-60 Ton) [4368 h]; Flat Bed Trailer [4368 h] | 2,318,883.81 | 1.3.10.50 | CONS | DEMOB | CIVIL | OK |
|  | 6 | **Complete demobilzation and site clean-up as Contract Conditions** |  | 2017-12-16 | 2018-01-29 |  |  |  |  |  |  |  |  |  |  |
| CO-PD-DM-DM-GE-0010 |  | Demobilization & Restoring of Storehouse (relocated from Block-6) to Designated Area | 31d | 2017-12-16 | 2018-01-20 | GE-GE-GE-GE-GE-0010 FS+493d | 9d |  | Common Labor / Helper [78 h]; Operator - Loader [39 h] | 94,010.45 | 1.3.10.60 | CONS | DEMOB | DEMOB | OK |
| CO-PD-DM-DM-GE-0020 |  | Demobilization of Contractor's Site Offices & Facilities | 26d | 2017-12-31 | 2018-01-29 | GE-GE-GE-GE-GE-0010 FS+509d | 1d | 0d | DI Flanged Short Pipes, DI Tee, Puddle Sleeves, Nuts & Bolts, Gasket; Code Blue LV Cables; UPVC Tee & Elbows; GI Steel Ladders; Cholorination Skid; UPVC Pipes & Fittings including Blind Flanges; CS Pipe Sleeves & DI Fittings for Valve Boxes; Non-Metalic Inscet Screen 150 mm dia.; Direct Buried Valves & Gate Valves (200 mm dia.) for Irrigation; 3/4" Rigid Conduits PVC Coated; Direct Buried Irrigation Wires; LV Cables; PVC Conduits (Walkway & Landscape Lights; Traffic Signage; Client Offices (including AC); Furniture for Client Office; Parking Shades (10 Parkings) for Client Office; IT Req., Office Supplies & Consumables (Client Office); Masonry Block & Accessories; External Building Signage; Internal Signage & Tags; Paint - Epoxy Coating; Paint for Walls & Ceiling (Internal / External); Wooden Trellis & Canopy; Chain Link Fence & Gate; Pre-cast Concrete Fence (for Lift Stations); Steel Gate for Lift Stations; Water Proofing & Roofing System; FRP - Ladders, Covers & Gratting; Lifting Hoist for Lift Stations; Door Hardware & Accessories; Sanitary Plumbing Fixtures & Toilet Accessories; Snack Bar Counter & Cabinet; Aluminum Windows; Glass Blocks (for Toilets); Gypum Board & Accessories (Toilets & Snack Bars); Mosaic Tiles (for Toilets); Quarry Tiles (for Toilets); Avonite Counter top with Cabinet (Toilets); Odor Control System Accessories; HVAC Ducts, Grills and Accessories; FRP Manholes & Lamination; Window Type AC; Fire Extinguishers; Package Type AC; DDC Panels (HVAC for Lift Stations); Fire Alarm System; SACS System; CCTV System; IP Phone System; Steel Pipes Fusion Coated (for Road - 5 & Road - 1 Crossing); Junction Boxes - Explosion Proof (for Lift Stations); Electrical Switches & Panel NEMA 4X (for Lift Stations); Excavator; Loader; Forklift; Dump Truck; Grader; Mobile Crane ( 25-60 Ton); Bobcat; Concrete Transit Mixers; Concrete Pump; Asphalt Paver; Asphalt Compactor / Roller; Flat Bed Trailer; Roller-Compactor (2~10 Ton); Roller-Compactor (25 Ton); Plate Compactor; Vibrators; Water Tanker; Fuel Tanker; Toilet Partitions (Phenolic 19 mm thick); Air-Compressor 300/900 CFM + Hummer; Dewatering Pumps; Tower Light; Boom Truck (15 Ton); Manlift (Boom Truck); JCB; Steel Fixer; Shuttering Carpenter; Concrete Mason; Plumber; Electrician; Mechanical Technician; Welder; Common Labor / Helper; LC Crew; Fence Crew - Lift Station; Wood Works Crew; Gypsum Walls & Ceiling Crew; Road Works Crew; Finishing Work Crew; Hardscape Crew; Soft Landscaping Crew; Specialist Works Crew; Operator - Excavator; Operator - Loader; Operator - Forklift; Driver - Dump Truck; Scaffolder; Block Mason; Plaster Mason; Tiling Crew; Painter; RTR Pipe Crew; Water Proofing Crew; HVAC Crew; Operator - Grader; Operator - Mobile Crane; Operator - Bobcat; Driver - Conc. Transit Mixers; Operator - Concrete Pump; Operator - Asphalt Paver; Operator - Asphalt Compactor / Roller; Driver - Flat Bed Trailer; Operator - Roller-Compactor (2~10 Ton); Operator - Roller (25 Ton); Driver - Water Tanker; Driver - Fuel Tanker; Operator - Boom Truck (15 Ton); Operator - Manlift (Boom Truck); Operator - JCB; Drivers Light Duty; FOC - Copper Cables; Copper Splices; Co-Axial Cables; Splicing FOC; Code Blue Pedestal; Sand for Backfilling; Warning Tapes; Red Tiles; Ground Cable and Accessories; Manhole Frame & Covers; PVC Sub-ducts; Sub-ducts Plugging; Geogrid; Geotextile Fabric; Sub-base (Class -B); Aggregate Base Course; Asphalt; Concrete Curb & Gutter; Polyethene Sheet; Bituminus Paint; Ready Mix Concrete; Steel Reinforcement; Selected Fill (Backfilling); Road Marking Paint; Steel Pipe Bollards; Bench & Picnic Tables; Drinking Fountains; BBQ Grill with cover; Hand wash; Trash Receptacle; MV Cables; MV Cables Splicing & Repairing Kits; PVC Piles including Spacers; 10 M High Lighting Poles; Ligting Fixtures; Wiring Devices; Cable Markers; MCC Panels; Disconnect Switches; PVC Coated Conduits including Accessories; Instrumentation Materials; Concrete Foundation; LV & MV Cable Accessories; Exhaust Fan; UTP Cables; Data Cabinet with Components; Telecom Enclosure; Telephone Outlet, Conduiting, Cabling & Accessories; FOC - Fiber Optic Cables; Splice Closure; Adtran 850; TYPE "L" DOUBLE SIDED MDF 9' X 10 VERTICAL; TV Wall Brackets & Accessories; Code Blue Pedestals; Palm Trees; Washing Tonia Robusta - Trees; Jacaranda - Trees; Cassia Fistula - Trees; Albizia Julibrissin - Trees; Chamaerops Humilis - Trees; Cycas Revolute - Plant; Shurbs; Ground Covers; Gravel & Gravel Mulch, Gravel N0.4 PEA; Play Ground Sand & Sand Fill; Selected Fill; Precast Concrete Pavers, Interlocking Paver; Curb (Concrete Edger), Curb & Gutter; Rubber Tiles (Rubber Tile Surface); Protective Railing; Steel Bicycle Rack Assembly; Paint for Marking & Road Marking; Stainless Steel Hand Rails; Bermuda Turf Sod / Grass; Galvanized Pipe Railing covered with Rubber Guards 50 mm dia HD; Precast Round Crested Concrete Weir; Play Ground Equipment Accessories; Fitness Equipment Accessories; RTR Pipes & Fittings; Fire Hydrant including Break Check Valves; Gate Valves Direct Buried with Extension Spindle & Surface Box; Metallic Flanges, Pipes & Fittings (for Fire Hydrants); Guard Posts for Fire Hydrants; Dismantling Joints - Valve Box Fittings; Gate Valves, Butterfly Valves, Drain Valves, Air Release Valves | 94,010.45 | 1.3.10.60 | CONS | DEMOB | DEMOB | OK |
| CO-PD-DM-DM-GE-0030 |  | Demobilization of Client's Site Offices & Facilities | 26d | 2017-12-31 | 2018-01-29 | CO-PD-DM-DM-GE-0020 SS | 1d | 0d | Common Labor / Helper [2704 h]; Mobile Crane ( 25-60 Ton) [364 h]; Operator - Mobile Crane [338 h]; Flat Bed Trailer [364 h]; Driver - Flat Bed Trailer [338 h] | 94,010.45 | 1.3.10.60 | CONS | DEMOB | DEMOB | OK |
| CO-PD-DM-DM-GE-0040 |  | Demobilization of Site Storage Area, Yards & Fences | 26d | 2017-12-31 | 2018-01-29 | CO-PD-DM-DM-GE-0030 SS | 1d | 0d | Common Labor / Helper [3380 h]; Scaffolder [117 h]; Operator - Loader [39 h]; Driver - Dump Truck [39 h]; Operator - Mobile Crane [39 h]; Operator - Bobcat [39 h]; Loader [84 h]; Dump Truck [168 h]; Mobile Crane ( 25-60 Ton) [42 h]; Bobcat [42 h] | 94,010.45 | 1.3.10.60 | CONS | DEMOB | DEMOB | OK |
| CO-PD-DM-DM-GE-0050 |  | General Cleanup | 26d | 2017-12-31 | 2018-01-29 | CO-PD-DM-DM-GE-0040 SS | 1d |  | Common Labor / Helper [6760 h]; Operator - Loader [676 h]; Driver - Dump Truck [1352 h]; Operator - Bobcat [1352 h]; Dump Truck [1456 h]; Bobcat [1456 h]; Loader [728 h] | 94,010.45 | 1.3.10.60 | CONS | DEMOB | DEMOB | OK |

Notes:
- CO-PD-DM-AB-GE-0010: Expenses: (New Expense Item) 467940
- CO-PD-DM-RB-GE-0010: Expenses: (New Expense Item) 701909
- CO-PD-DM-PT-GE-0010: Expenses: (New Expense Item) 1685166
- CO-PD-DM-RD-GE-0010: Expenses: (New Expense Item) 288169
- CO-PD-DM-JB-GE-0010: Expenses: (New Expense Item) 2318884
- CO-PD-DM-DM-GE-0010: Expenses: (New Expense Item) 94010.4
- CO-PD-DM-DM-GE-0020: Expenses: (New Expense Item) 94010.4
- CO-PD-DM-DM-GE-0030: Expenses: (New Expense Item) 94010.4
- CO-PD-DM-DM-GE-0040: Expenses: (New Expense Item) 94010.4
- CO-PD-DM-DM-GE-0050: Expenses: (New Expense Item) 94010.4

## Activity codes

| Code | Value | Meaning |
| --- | --- | --- |
| RPI - BUILDINGS | LS12 | LIFT STATION # 12 |
| RPI - CONSTRUCTION | RPI - CONS | CONSTRUCTION |
| RPI - PHASE | 6 | CONSTRUCTION |
| RPI - TYPE OF WORK | CIVIL | CIVIL WORKS |
| RPI - TYPE OF WORK | ELEC | ELECTRICAL WORKS |
| RPI - TYPE OF WORK | MECH | MECHANICAL WORKS |
| RPI - UTILITY NETWORKS | POWER | Power Network |
| RPI - UTILITY NETWORKS | PW | Potable & Fire Water System |
| RPI - UTILITY NETWORKS | STORM | Storm Drainage System |
| RPI - ZONES | Z1 | ZONE-1 |
| RPI - ZONES | Z2 | ZONE-2 |
| RPI_P2 - AREAS | PATROL RD | PATROL ROAD |
| RPI_P2 - AREAS | REALM | PUBLIC REALM AREA |
| RPI_P2 - AREAS | ROAD-1 | ROAD - 1 |
| RPI_P2 - AREAS | ROAD-2 | ROAD - 2 |
| RPI_P2 - AREAS | ROAD-3 | ROAD - 3 |
| RPI_P2 - AREAS | ROAD-4 | ROAD - 4 |
| RPI_P2 - AREAS | ROAD-5 | ROAD - 5 |
| RPI_P2 - AREAS | ROAD-A | ROAD - A |
| RPI_P2 - AREAS | ROAD-B | ROAD - B |
| RPI_P2 - AREAS | ROAD-E | ROAD - E |
| RPI_P2 - BOQ ITEMS | 1.2.1.10 | M-Fiber Optiic & Copper Cable System |
| RPI_P2 - BOQ ITEMS | 1.2.1.20 | M-Communication & Security Sys |
| RPI_P2 - BOQ ITEMS | 1.2.1.30 | M-Communication MH & Conduit Sys |
| RPI_P2 - BOQ ITEMS | 1.2.1.40 | M-Misc. Communication Items |
| RPI_P2 - BOQ ITEMS | 1.2.10.10 | M-Communication & Security Sys. |
| RPI_P2 - BOQ ITEMS | 1.2.10.20 | M-Misc. Communication Sys. |
| RPI_P2 - BOQ ITEMS | 1.2.11.10 | M-Potable and Fire Water System & related Mat. |
| RPI_P2 - BOQ ITEMS | 1.2.11.20 | M-Sea Water System & related Mat. |
| RPI_P2 - BOQ ITEMS | 1.2.11.30 | M-Sanitary Sewer System & related Mat. |
| RPI_P2 - BOQ ITEMS | 1.2.11.40 | M-Irrigation System and related Mat. |
| RPI_P2 - BOQ ITEMS | 1.2.2.10 | M-All Palm Trees & Soft Landscape Mat. |
| RPI_P2 - BOQ ITEMS | 1.2.3.10 | M-Road Works Related Mat. |
| RPI_P2 - BOQ ITEMS | 1.2.3.20 | M-Concrete Works Related Mat. |
| RPI_P2 - BOQ ITEMS | 1.2.3.30 | M-All Other Misc. Items |
| RPI_P2 - BOQ ITEMS | 1.2.4.10 | M-Medium Voltage Cables |
| RPI_P2 - BOQ ITEMS | 1.2.4.20 | M-Motor Control Gear |
| RPI_P2 - BOQ ITEMS | 1.2.4.30 | M-Street Lighting, Solar Lighting & Fix. |
| RPI_P2 - BOQ ITEMS | 1.2.4.40 | M-Misc. Electrical Items |
| RPI_P2 - BOQ ITEMS | 1.2.5.10 | M-Fiber Optic and Copper Cable System |
| RPI_P2 - BOQ ITEMS | 1.2.5.20 | M-Communication and Security Sys |
| RPI_P2 - BOQ ITEMS | 1.2.5.30 | M-Communication MH & Conduit Sys |
| RPI_P2 - BOQ ITEMS | 1.2.5.40 | M-Misc. Communication Items |
| RPI_P2 - BOQ ITEMS | 1.2.6.10 | M-All Palm trees, Plants, Shrubs & Softscape Mat. |
| RPI_P2 - BOQ ITEMS | 1.2.6.20 | M-All Concrete Tiles, furniture & Hardscape Mat. |
| RPI_P2 - BOQ ITEMS | 1.2.6.30 | M-Fitness & Play ground Equipments |
| RPI_P2 - BOQ ITEMS | 1.2.7.10 | M-Potable & Fire Water Sys. & related Mat. |
| RPI_P2 - BOQ ITEMS | 1.2.7.20 | M-Sea Water System & Related Mat. |
| RPI_P2 - BOQ ITEMS | 1.2.7.30 | M-Sanitary Sewer System & Related Mat. |
| RPI_P2 - BOQ ITEMS | 1.2.7.40 | M-Irrigation System & Related Mat. |
| RPI_P2 - BOQ ITEMS | 1.2.7.50 | M-Lighting Network System & related Mat. |
| RPI_P2 - BOQ ITEMS | 1.2.8.10 | M-Concrete works related material |
| RPI_P2 - BOQ ITEMS | 1.2.8.20 | M-All Other Misc. Items |
| RPI_P2 - BOQ ITEMS | 1.2.9.10 | M-Medium Voltage Cables |
| RPI_P2 - BOQ ITEMS | 1.2.9.20 | M-Motor Control Gear |
| RPI_P2 - BOQ ITEMS | 1.2.9.30 | M-Misc. Electrical Items |
| RPI_P2 - BOQ ITEMS | 1.3.1.10 | C-Complete Construction Mobilization & Temp. Facilities |
| RPI_P2 - BOQ ITEMS | 1.3.1.20 | C-Approved Work Schedule |
| RPI_P2 - BOQ ITEMS | 1.3.1.30 | C-Approved Conctractor Project Execution Plan |
| RPI_P2 - BOQ ITEMS | 1.3.1.40 | C-Security Services for all Zones |
| RPI_P2 - BOQ ITEMS | 1.3.10.10 | C-Complete As-Built CADD |
| RPI_P2 - BOQ ITEMS | 1.3.10.20 | C-Approved Project Record Books |
| RPI_P2 - BOQ ITEMS | 1.3.10.30 | C-Complete Restoration of Palm Trees |
| RPI_P2 - BOQ ITEMS | 1.3.10.40 | C-Complete Restoration of Previous Damages to Site for all Research Park Zones |
| RPI_P2 - BOQ ITEMS | 1.3.10.50 | C-Complete Jersey Barrier Removal for All Research Park Zones |
| RPI_P2 - BOQ ITEMS | 1.3.10.60 | C-Complete Demobilization and Site Clean-up as per Contract Conditions |
| RPI_P2 - BOQ ITEMS | 1.3.2.10 | C-Communication & Security Systems |
| RPI_P2 - BOQ ITEMS | 1.3.3.10 | C-Site Preparation, demolition & earthwork |
| RPI_P2 - BOQ ITEMS | 1.3.3.100 | C-Communication & Security System |
| RPI_P2 - BOQ ITEMS | 1.3.3.20 | C-Potable & Fire Water System |
| RPI_P2 - BOQ ITEMS | 1.3.3.30 | C-Sea Water System |
| RPI_P2 - BOQ ITEMS | 1.3.3.40 | C-Sanitary Sewer System |
| RPI_P2 - BOQ ITEMS | 1.3.3.50 | C-Irrigation Water System |
| RPI_P2 - BOQ ITEMS | 1.3.3.60 | C-Storm Water Drainage System |
| RPI_P2 - BOQ ITEMS | 1.3.3.70 | C-Road Networks |
| RPI_P2 - BOQ ITEMS | 1.3.3.90 | C-Electrical Works |
| RPI_P2 - BOQ ITEMS | 1.3.4.10 | C-Liftstation no. 10 and 11 |
| RPI_P2 - BOQ ITEMS | 1.3.5.10 | C-Site Preparation, demolition & earthwork |
| RPI_P2 - BOQ ITEMS | 1.3.5.20 | C-Potable & Fire Water System |
| RPI_P2 - BOQ ITEMS | 1.3.5.30 | C-Sea Water System |
| RPI_P2 - BOQ ITEMS | 1.3.5.40 | C-Sanitary Sewer System |
| RPI_P2 - BOQ ITEMS | 1.3.5.50 | C-Irrigation Water System |
| RPI_P2 - BOQ ITEMS | 1.3.5.60 | C-Storm Water Drainage System |
| RPI_P2 - BOQ ITEMS | 1.3.5.70 | C-Electrical Works |
| RPI_P2 - BOQ ITEMS | 1.3.5.80 | C-Communication & Security System |
| RPI_P2 - BOQ ITEMS | 1.3.6.10 | C-Lift Station no. 9 |
| RPI_P2 - BOQ ITEMS | 1.3.7.10 | C-Replace Dead Palm Trees & Dispose Off in Zone-2 |
| RPI_P2 - BOQ ITEMS | 1.3.7.20 | C-Replace Dead Palm Trees & Dispose Off in Zone-3 |
| RPI_P2 - BOQ ITEMS | 1.3.7.30 | C-Landscaping in Zone-3 |
| RPI_P2 - BOQ ITEMS | 1.3.8.10 | C-Toilet Facilities |
| RPI_P2 - BOQ ITEMS | 1.3.8.20 | C-Snack Booths |
| RPI_P2 - BOQ ITEMS | 1.3.8.30 | C-Picnic Shelters |
| RPI_P2 - BOQ ITEMS | 1.3.8.40 | C-Fitness Shelters |
| RPI_P2 - BOQ ITEMS | 1.3.8.50 | C-Art Works Shelters |
| RPI_P2 - BOQ ITEMS | 1.3.9.10 | C-Approved Pre-commissioning Plans |
| RPI_P2 - BOQ ITEMS | 1.3.9.20 | C-Approved Operating Spare Parts Data Packages |
| RPI_P2 - BOQ ITEMS | 1.3.9.30 | C-Approved Operation & Maintenance Manuals |
| RPI_P2 - BOQ ITEMS | 1.3.9.40 | C-Complete pre-commissioning |
| RPI_P2 - BUILDINGS | AEB | Alternate Exchange Building |
| RPI_P2 - BUILDINGS | Art S-1 | Art Shelter # 1 |
| RPI_P2 - BUILDINGS | Art S-2 | Art Shelter # 2 |
| RPI_P2 - BUILDINGS | Art S-3 | Art Shelter # 3 |
| RPI_P2 - BUILDINGS | Art S-4 | Art Shelter # 4 |
| RPI_P2 - BUILDINGS | Art S-5 | Art Shelter # 5 |
| RPI_P2 - BUILDINGS | Art S-6 | Art Shelter # 6 |
| RPI_P2 - BUILDINGS | Art S-7 | Art Shelter # 7 |
| RPI_P2 - BUILDINGS | Art S-8 | Art Shelter # 8 |
| RPI_P2 - BUILDINGS | Drainage P-4 | Drainage Pond # 4 |
| RPI_P2 - BUILDINGS | Drainage P-6 | Drainage Pond # 6 |
| RPI_P2 - BUILDINGS | Drainage P-7 | Drainage Pond # 7 |
| RPI_P2 - BUILDINGS | Drainage P-8 | Drainage Pond # 8 |
| RPI_P2 - BUILDINGS | Drainage P-9 | Drainage Pond # 9 |
| RPI_P2 - BUILDINGS | Fitness S-1 | Fitness Shelter # 1 |
| RPI_P2 - BUILDINGS | Fitness S-2 | Fitness Shelter # 2 |
| RPI_P2 - BUILDINGS | Fitness S-3 | Fitness Shelter # 3 |
| RPI_P2 - BUILDINGS | Fitness S-4 | Fitness Shelter # 4 |
| RPI_P2 - BUILDINGS | Fitness S-5 | Fitness Shelter # 5 |
| RPI_P2 - BUILDINGS | Fitness S-6 | Fitness Shelter # 6 |
| RPI_P2 - BUILDINGS | Fitness S-7 | Fitness Shelter # 7 |
| RPI_P2 - BUILDINGS | LS-10 | Lift Station # 10 |
| RPI_P2 - BUILDINGS | LS-11 | Lift Station # 11 |
| RPI_P2 - BUILDINGS | LS-9 | Lift Station # 09 |
| RPI_P2 - BUILDINGS | SS4 | Sub-Station # 4 |
| RPI_P2 - BUILDINGS | SS5 | Sub-Station # 5 |
| RPI_P2 - BUILDINGS | Snack-1 | Snack Booth # 1 |
| RPI_P2 - BUILDINGS | Snack-2 | Snack Booth # 2 |
| RPI_P2 - BUILDINGS | Snack-3 | Snack Booth # 3 |
| RPI_P2 - BUILDINGS | Snack-4 | Snack Booth # 4 |
| RPI_P2 - BUILDINGS | Toilet-1 | Toilet # 1 |
| RPI_P2 - BUILDINGS | Toilet-2 | Toilet # 2 |
| RPI_P2 - BUILDINGS | Toilet-3 | Toilet # 3 |
| RPI_P2 - CONSTRUCTION | CONS | CONSTRUCTION |
| RPI_P2 - CROSSINGS | ROAD-1 XING | ROAD - 1 CROSSING |
| RPI_P2 - CROSSINGS | ROAD-5 XING | ROAD - 5 CROSSING |
| RPI_P2 - DISCIPLINE / WORK TYPE | CIVIL | CIVIL WORKS |
| RPI_P2 - DISCIPLINE / WORK TYPE | COMM | COMMUNICATION WORKS |
| RPI_P2 - DISCIPLINE / WORK TYPE | DEMOB | DEMOBILIZATION |
| RPI_P2 - DISCIPLINE / WORK TYPE | ELEC | ELECTRICAL WORKS |
| RPI_P2 - DISCIPLINE / WORK TYPE | GEN | GENERAL WORKS |
| RPI_P2 - DISCIPLINE / WORK TYPE | HARDSCAPE | HARDSCAPING WORKS |
| RPI_P2 - DISCIPLINE / WORK TYPE | MECH | MECHANICAL WORKS |
| RPI_P2 - DISCIPLINE / WORK TYPE | MOB | MOBILIZATION |
| RPI_P2 - DISCIPLINE / WORK TYPE | ROAD | ROAD WORKS |
| RPI_P2 - DISCIPLINE / WORK TYPE | SOFTSCAPE | SOFT LANDSCAPING WORKS |
| RPI_P2 - PHASE | CONS | CONSTRUCTION |
| RPI_P2 - PHASE | DEMOB | DE-MOBILIZATION |
| RPI_P2 - PHASE | ENG | ENGINEERING |
| RPI_P2 - PHASE | GEN | GENERAL |
| RPI_P2 - PHASE | MOB | MOBILIZATION |
| RPI_P2 - PHASE | PROC | PROCUREMENT |
| RPI_P2 - PHASE | TC | TESTING & PRE-COMMISSIONING |
| RPI_P2 - PROCUREMENT | PROC | PROCUREMENT |
| RPI_P2 - UTILITY NETWORK | COMM | Communication Network |
| RPI_P2 - UTILITY NETWORK | IRR | Irrigation Water System |
| RPI_P2 - UTILITY NETWORK | POWER | Power Network |
| RPI_P2 - UTILITY NETWORK | PW | Potable & Fire Water System |
| RPI_P2 - UTILITY NETWORK | ROAD | Roads |
| RPI_P2 - UTILITY NETWORK | SEA-W | Sea Water System |
| RPI_P2 - UTILITY NETWORK | SEWER | Sewer System |
| RPI_P2 - UTILITY NETWORK | STORM | Storm Drainage System |
| RPI_P2 - ZONES | ZONE-1&2 | ZONE - 1 & 2 |
| RPI_P2 - ZONES | ZONE-2 | ZONE - 2 |
| RPI_P2 - ZONES | ZONE-3 | ZONE - 3 |
| RPI_P2 - ZONES | ZONE-4 | ZONE - 4 |
