# KAUST - R3-Balance Works Schedule - By Zones

Schedule from Primavera P6, 2014-02-01 to 2014-12-31, data date 2014-02-01.
Must finish by 2014-12-31

## Calendars

- SSH-Calendar: Mon-Thu 07:00-17:00; Fri off; Sat-Sun 07:00-17:00.

## Resources

| Resource | Group |
| --- | --- |
| SSH-Construction Manhours | labor |

## Schedule

| ID | WBS | Activity | Type | Duration | Start | Finish | Predecessors | Total float | Free float | Resources | Department |
| --- | --- | --- | --- | --- | --- | --- | --- | --- | --- | --- | --- |
| RC.Z1.111 |  | Road 6 diversion (Eng'g+Safety Works+Installation) |  | 15d | 2014-02-01 | 2014-02-13 | Eng.110 SS | -0.5d | 0d | SSH-Construction Manhours [800 h] | Z1 |
| RC.Z2.111 |  | Road Crossing for Road 7 |  | 30d | 2014-02-01 | 2014-02-27 | RC.Z1.111 SS | -0.5d | 0d | SSH-Construction Manhours [1200 h] | Z2 |
| RC.Z1.112 |  | Road Crossing # 122 & 131 Utilities Installation |  | 22d | 2014-02-15 | 2014-03-06 | RC.Z1.111 | 128.5d | 0d | SSH-Construction Manhours [1200 h] | Z1 |
| RC.Z2.112 |  | Road Crossing for Road C |  | 30d | 2014-03-01 | 2014-03-27 | RC.Z2.111 | 61.5d | 0d | SSH-Construction Manhours [1200 h] | Z2 |
| E.RMU.Z1.111 |  | RMU installation - Z1 (Exc+Fdn+RMU Ins+BKFG) |  | 15d | 2014-03-06 | 2014-03-20 | RC.Z1.112 | 188.5d | 60d | SSH-Construction Manhours [800 h] | Z1 |
| GFL.170 |  | Installation of Sewer manhole zone 1 |  | 15d | 2014-03-16 | 2014-03-30 | PFW.125 SS+10d | 178.5d | 50d | SSH-Construction Manhours [400 h] | Z1 |
| RC.Z2.113 |  | Road Crossing for Road D |  | 21d | 2014-03-29 | 2014-04-16 | RC.Z2.112 | 61.5d | 0d | SSH-Construction Manhours [400 h] | Z2 |
| SW.147 |  | Backfilling Seawater Line Towards Intake Plant |  | 21d | 2014-04-21 | 2014-05-11 | SW.146 SS+12d | 133.5d | 5d | SSH-Construction Manhours [500 h] | Z1 |
| Z1.999 |  | Zone 1 Works Finish | milestone | 0d | 2014-05-15 | 2014-05-15 | E.RMU.Z1.111, SD.22.131, GFL.170, SW.NCL24.111, SW.146, PFW.125, RC.Z1.112, SW.147 | 128.5d | 8d |  | Z1 |
| Z2.999 |  | Zone 2 Works Finish | milestone | 0d | 2014-09-30 | 2014-09-30 | COM.Z2.151, E.CCTV.Z2.111, RD.191, RC.191, SD.DP10.131, SD.BC02.131, LS12.999, LS12.240, GFL.160, IRR.158, SW.NCL03.111, SW.154, PFW.159, PFW.149, PFW.126, RC.Z2.113 | 55.5d | 54d |  | Z2 |
|  | 1 | **Engineering** |  |  | 2014-02-01 | 2014-12-20 |  |  |  |  |  |
| Eng.110 |  | Resolve Engineering Issues |  | 60d | 2014-02-01 | 2014-03-27 |  | -0.5d | 0d |  | ENG |
| Eng.200 |  | Submit As-Built Drawings with CADD Data for Power Distribution |  | 30d | 2014-07-14 | 2014-08-10 | E.Works.999, SS4.999, SS5.999 | 20.5d | 0d | SSH-Construction Manhours [1460 h] | ENG |
| Eng.150 |  | Submit As-Built Drawings with CADD Data for Irrigation network |  | 30d | 2014-08-02 | 2014-08-28 | IRR.999 | 120.5d | 0d | SSH-Construction Manhours [1460 h] | ENG |
| Eng.130 |  | Submit As-Built Drawings with CADD Data for PW/FW network |  | 30d | 2014-08-20 | 2014-09-17 | PFW.999 | 99.5d | 0d | SSH-Construction Manhours [1460 h] | ENG |
| Eng.140 |  | Submit As-Built Drawings with CADD Data for Seawater network |  | 30d | 2014-08-25 | 2014-09-21 | SW.999 | 95.5d | 0d | SSH-Construction Manhours [1460 h] | ENG |
| Eng.180 |  | Submit As-Built Drawings with CADD Data for Road network |  | 20d | 2014-11-03 | 2014-11-20 | RD.999 | 30.5d | 0d | SSH-Construction Manhours [1460 h] | ENG |
| Eng.160 |  | Submit As-Built Drawings with CADD Data for Sewer network |  | 30d | 2014-11-20 | 2014-12-18 | GFL.999, LS12.999, LS9.999, LS10.999, LS11.999 | 1.5d | 0d | SSH-Construction Manhours [1460 h] | ENG |
| Eng.190 |  | Submit As-Built Drawings with CADD Data for Public Realm |  | 30d | 2014-11-20 | 2014-12-18 | SB3.999, SB4.999, PR.S2.571, PR.S3.371, T2.999, T1.999, T3.999, SB2.999, PR.S4.131, PR.Works.999, SB1.999 | 1.5d | 0d | SSH-Construction Manhours [1460 h] | ENG |
| Eng.210 |  | Submit As-Built Drawings with CADD Data for Telecomm Works |  | 30d | 2014-11-22 | 2014-12-18 | TCOM.999, Eng.200, AEB.999 | 0.5d | 0d | SSH-Construction Manhours [1460 h] | ENG |
| Eng.170 |  | Submit As-Built Drawings with CADD Data for Storm Drainage system |  | 20d | 2014-12-01 | 2014-12-20 | SD.Works.999 | -0.5d | 0d | SSH-Construction Manhours [1460 h] | ENG |
|  | 2 | **Procurement** |  |  |  |  |  |  |  |  |  |
|  | 3 | **Site Preparation - Backfilling** |  |  | 2014-02-01 | 2014-07-03 |  |  |  |  |  |
| B.110 |  | Final verification of blcoks 9A, 9B |  | 15d | 2014-02-01 | 2014-02-13 | Eng.110 SS | 192.5d | 0d | SSH-Construction Manhours [400 h] | Z3 |
| B.120 |  | Final verification of blcoks 10A, 10B |  | 15d | 2014-02-15 | 2014-02-27 | B.110 | 192.5d | 0d | SSH-Construction Manhours [400 h] | Z3 |
| B.130 |  | Final verification of blcoks 6A, 6B, 6C, 6D, 6E |  | 45d | 2014-03-01 | 2014-04-10 | B.120 | 192.5d | 0d | SSH-Construction Manhours [400 h] | Z3 |
| B.140 |  | Final verification of blcoks 7A, 7B, 7C, 7D, 7E, 7F, 7G |  | 60d | 2014-04-12 | 2014-06-05 | B.130 | 192.5d | 0d | SSH-Construction Manhours [400 h] | Z3 |
| B.150 |  | Final verification of blcoks 8A, 8B, 8C |  | 30d | 2014-06-07 | 2014-07-03 | B.140 | 192.5d | 0d | SSH-Construction Manhours [400 h] | Z3 |
| B.999 |  | Site Preparation Finish | milestone | 0d | 2014-07-03 | 2014-07-03 | B.140, B.150, B.120, B.130, B.110 | 192.5d | 193d |  | Z3 |

| ID | WBS | Activity | Type | Duration | Start | Finish | Predecessors | Total float | Free float | Resources | Department |
| --- | --- | --- | --- | --- | --- | --- | --- | --- | --- | --- | --- |
|  | 4 | **Potable & Firewater Network** |  |  | 2014-02-01 | 2014-08-20 |  |  |  |  |  |
| PFW.110 |  | Resolve Procurement & Engineering Issues |  | 30d | 2014-02-01 | 2014-02-27 | Eng.110 SS | 99.5d | 0d | SSH-Construction Manhours | MGT |
| PFW.AV01.111 |  | Balance Construction of AV01 |  | 30d | 2014-02-05 | 2014-03-05 | PFW.110 SS+6d | 99.5d | 0d | SSH-Construction Manhours [500 h] | Z3 |
| PFW.120 |  | Balance Pipe Installation - along Road 2 |  | 30d | 2014-02-15 | 2014-03-13 | PFW.110 SS+15d | 150.5d | 0d | SSH-Construction Manhours [800 h] | Z3 |
| PFW.123 |  | Balance Pipe Installation - along Road 2 |  | 30d | 2014-02-15 | 2014-03-13 | RC.Z2.111 SS+15d | 120.5d | 0d | SSH-Construction Manhours [800 h] | Z2 |
| PFW.140 |  | Hydrotest - along Road 4 |  | 15d | 2014-02-15 | 2014-02-27 | PFW.120 SS | 150.5d | 0d | SSH-Construction Manhours [200 h] | Z3 |
| PFW.AV02.111 |  | Balance Construction of AV02 |  | 30d | 2014-02-24 | 2014-03-24 | PFW.AV01.111 SS+20d | 99.5d | 0d | SSH-Construction Manhours [800 h] | Z3 |
| PFW.141 |  | Hydrotest - along Road B |  | 15d | 2014-03-01 | 2014-03-13 | PFW.140 | 150.5d | 0d | SSH-Construction Manhours [200 h] | Z3 |
| PFW.150 |  | Sand covering + trench backfilling + compaction-along Rd 4 |  | 15d | 2014-03-01 | 2014-03-13 | PFW.140 SS+15d | 150.5d | 0d | SSH-Construction Manhours [600 h] | Z3 |
| PFW.125 |  | Balance Pipe Installation - along Road 6 |  | 21d | 2014-03-06 | 2014-03-26 | RC.Z1.112 | 167.5d | 0d | SSH-Construction Manhours [800 h] | Z1 |
| PFW.121 |  | Balance Pipe Installation - along Road 3 |  | 30d | 2014-03-15 | 2014-04-10 | PFW.120 | 170.5d | 0d | SSH-Construction Manhours [800 h] | Z3 |
| PFW.124 |  | Balance Pipe Installation - along Road 7 |  | 30d | 2014-03-15 | 2014-04-10 | PFW.123 | 120.5d | 0d | SSH-Construction Manhours [800 h] | Z2 |
| PFW.142 |  | Hydrotest - along Road A |  | 15d | 2014-03-15 | 2014-03-27 | PFW.141 | 150.5d | 0d | SSH-Construction Manhours [200 h] | Z3 |
| PFW.146 |  | Hydrotest - along Road 2 |  | 15d | 2014-03-15 | 2014-03-27 | PFW.123 | 135.5d | 0d | SSH-Construction Manhours [200 h] | Z2 |
| PFW.151 |  | Sand covering + trench backfilling + compaction-along Rd B |  | 15d | 2014-03-15 | 2014-03-27 | PFW.141, PFW.150 | 150.5d | 0d | SSH-Construction Manhours [600 h] | Z3 |
| PFW.AV03.111 |  | Balance Construction of AV03 |  | 30d | 2014-03-15 | 2014-04-12 | PFW.AV02.111 SS+20d | 99.5d | 0d | SSH-Construction Manhours [800 h] | Z3 |
| PFW.143 |  | Hydrotest - along Road 2 |  | 15d | 2014-03-29 | 2014-04-10 | PFW.120, PFW.142 | 170.5d | 0d | SSH-Construction Manhours [200 h] | Z3 |
| PFW.152 |  | Sand covering + trench backfilling + compaction-along Rd A |  | 35d | 2014-03-29 | 2014-04-29 | PFW.151, PFW.142 | 150.5d | 0d | SSH-Construction Manhours [600 h] | Z3 |
| PFW.156 |  | Sand covering + trench backfilling + compaction-along Rd 2 |  | 25d | 2014-03-29 | 2014-04-20 | PFW.146 | 135.5d | 5d | SSH-Construction Manhours [600 h] | Z2 |
| PFW.AV04.111 |  | Balance Construction of AV04 |  | 30d | 2014-04-02 | 2014-04-30 | PFW.AV03.111 SS+20d | 99.5d | 0d | SSH-Construction Manhours [800 h] | Z3 |
| PFW.122 |  | Balance Pipe Installation - along Road 5 |  | 30d | 2014-04-12 | 2014-05-08 | PFW.121 | 170.5d | 0d | SSH-Construction Manhours [800 h] | Z3 |
| PFW.126 |  | Balance Pipe Installation - Towards Utility Plant |  | 45d | 2014-04-12 | 2014-05-22 | PFW.124 | 120.5d | 0d | SSH-Construction Manhours [1200 h] | Z2 |
| PFW.144 |  | Hydrotest - along Road 3 |  | 15d | 2014-04-12 | 2014-04-24 | PFW.121, PFW.143 | 175.5d | 15d | SSH-Construction Manhours [200 h] | Z3 |
| PFW.147 |  | Hydrotest - along Road 7 |  | 15d | 2014-04-12 | 2014-04-24 | PFW.146, PFW.124 | 130.5d | 0d | SSH-Construction Manhours [200 h] | Z2 |
| PFW.AV05.111 |  | Balance Construction of AV05 |  | 30d | 2014-04-21 | 2014-05-19 | PFW.AV04.111 SS+20d | 99.5d | 0d | SSH-Construction Manhours [800 h] | Z3 |
| PFW.148 |  | Hydrotest - along Road 6 |  | 15d | 2014-04-26 | 2014-05-08 | PFW.147, PFW.125 | 135.5d | 10d | SSH-Construction Manhours [200 h] | Z2 |
| PFW.157 |  | Sand covering + trench backfilling + compaction-along Rd 7 |  | 25d | 2014-04-26 | 2014-05-18 | PFW.147, PFW.156 | 130.5d | 0d | SSH-Construction Manhours [1200 h] | Z2 |
| PFW.153 |  | Sand covering + trench backfilling + compaction-along Rd 2 |  | 20d | 2014-04-30 | 2014-05-18 | PFW.143, PFW.152 | 150.5d | 0d | SSH-Construction Manhours [600 h] | Z3 |
| PFW.145 |  | Hydrotest - along Road 5 |  | 15d | 2014-05-10 | 2014-05-22 | PFW.144, PFW.122 | 170.5d | 20d | SSH-Construction Manhours [200 h] | Z3 |
| PFW.AV06.111 |  | Balance Construction of AV06 |  | 30d | 2014-05-10 | 2014-06-07 | PFW.AV05.111 SS+20d | 99.5d | 0d | SSH-Construction Manhours [800 h] | Z3 |
| PFW.154 |  | Sand covering + trench backfilling + compaction-along Rd 3 |  | 25d | 2014-05-19 | 2014-06-10 | PFW.144, PFW.153 | 150.5d | 0d | SSH-Construction Manhours [600 h] | Z3 |
| PFW.158 |  | Sand covering + trench backfilling + compaction-along Rd 6 |  | 25d | 2014-05-19 | 2014-06-10 | PFW.157, PFW.148 | 130.5d | 10d | SSH-Construction Manhours [600 h] | Z2 |
| PFW.149 |  | Hydrotest -Line towards utiltiy Plant |  | 30d | 2014-05-24 | 2014-06-19 | PFW.126, PFW.148, Z1.999 | 120.5d | 0d | SSH-Construction Manhours [800 h] | Z2 |
| PFW.AV07.111 |  | Balance Construction of AV07 |  | 30d | 2014-05-28 | 2014-06-25 | PFW.AV06.111 SS+20d | 99.5d | 0d | SSH-Construction Manhours [800 h] | Z3 |
| PFW.155 |  | Sand covering + trench backfilling + compaction-along Rd 5 |  | 25d | 2014-06-11 | 2014-07-03 | PFW.145, PFW.154 | 150.5d | 51d | SSH-Construction Manhours [600 h] | Z3 |
| PFW.AV08.111 |  | Balance Construction of AV08 |  | 30d | 2014-06-16 | 2014-07-14 | PFW.AV07.111 SS+20d | 99.5d | 0d | SSH-Construction Manhours [800 h] | Z3 |
| PFW.159 |  | Sand covering + trench backfilling + compaction-Line towards Utility Plant |  | 45d | 2014-06-21 | 2014-07-31 | PFW.149, PFW.158 | 120.5d | 21d | SSH-Construction Manhours [800 h] | Z2 |
| PFW.AV09.111 |  | Balance Construction of AV09 |  | 30d | 2014-07-05 | 2014-08-02 | PFW.AV08.111 SS+20d | 99.5d | 0d | SSH-Construction Manhours [800 h] | Z3 |
| PFW.AV10.111 |  | Balance Construction of AV10 |  | 30d | 2014-07-23 | 2014-08-20 | PFW.AV09.111 SS+20d | 99.5d | 0d | SSH-Construction Manhours [800 h] | Z3 |
| PFW.999 |  | Potable & Firewater Network Finish | milestone | 0d | 2014-08-20 | 2014-08-20 | PFW.153, PFW.151, PFW.152, PFW.154, PFW.158, PFW.150, PFW.AV10.111, PFW.155, PFW.156, PFW.157, PFW.159 | 99.5d | 0d |  | Z3 |

| ID | WBS | Activity | Type | Duration | Start | Finish | Predecessors | Total float | Free float | Resources | Department |
| --- | --- | --- | --- | --- | --- | --- | --- | --- | --- | --- | --- |
|  | 5 | **Seawater Network** |  |  | 2014-02-01 | 2014-08-24 |  |  |  |  |  |
| SW.110 |  | Resolve Procurement & Engineering Issues |  | 25d | 2014-02-01 | 2014-02-23 | Eng.110 SS | 125.5d | 0d | SSH-Construction Manhours | MGT |
| SW.120 |  | Balance Pipe Installation - Along Road 2 |  | 30d | 2014-02-15 | 2014-03-13 | SW.110 SS+15d | 145.5d | 0d | SSH-Construction Manhours [1000 h] | Z3 |
| SW.130 |  | Excavation - Towards Intake Plant |  | 21d | 2014-03-06 | 2014-03-26 | RC.Z1.112 | 128.5d | 0d | SSH-Construction Manhours [800 h] | Z1 |
| SW.121 |  | Balance Pipe Installation - Along Road 3 |  | 30d | 2014-03-15 | 2014-04-10 | SW.120 | 145.5d | 0d | SSH-Construction Manhours [1000 h] | Z3 |
| SW.124 |  | Balance Pipe Installation - Along Road 6 |  | 30d | 2014-03-15 | 2014-04-10 | RC.Z2.112 SS+15d | 95.5d | 0d | SSH-Construction Manhours [1000 h] | Z2 |
| SW.140 |  | Hydrotest - Along Road 2 |  | 15d | 2014-03-15 | 2014-03-27 | SW.120 | 150.5d | 0d | SSH-Construction Manhours [500 h] | Z3 |
| SW.NCL01.111 |  | Balance Construction of NCL01 |  | 30d | 2014-03-15 | 2014-04-10 | SW.110, SW.124 SS | 105.5d | 0d | SSH-Construction Manhours [800 h] | Z2 |
| SW.131 |  | Pipe Installation - Towards Intake Plant |  | 21d | 2014-03-22 | 2014-04-10 | SW.130 SS+16d | 128.5d | 0d | SSH-Construction Manhours [800 h] | Z1 |
| SW.NCL24.111 |  | Construction of NCL24 |  | 30d | 2014-03-26 | 2014-04-23 | SW.130 | 152.5d | 24d | SSH-Construction Manhours [800 h] | Z1 |
| SW.150 |  | Sand covering + trench backfilling + compaction-Along Rd 2 |  | 15d | 2014-03-29 | 2014-04-10 | SW.140 | 150.5d | 15d | SSH-Construction Manhours [800 h] | Z3 |
| SW.146 |  | Hydrotest - Line towards Intake Plant |  | 21d | 2014-04-10 | 2014-04-29 | SW.131 | 133.5d | 0d | SSH-Construction Manhours [600 h] | Z1 |
| SW.122 |  | Balance Pipe Installation - Along Road 5 crossing |  | 30d | 2014-04-12 | 2014-05-08 | SW.121, SW.120 | 145.5d | 0d | SSH-Construction Manhours [1000 h] | Z3 |
| SW.125 |  | Balance Pipe Installation - Along Road 7 |  | 30d | 2014-04-12 | 2014-05-08 | SW.124 | 95.5d | 0d | SSH-Construction Manhours [1000 h] | Z2 |
| SW.141 |  | Hydrotest - Along Road 3 |  | 15d | 2014-04-12 | 2014-04-24 | SW.140, SW.121 | 180.5d | 0d | SSH-Construction Manhours [500 h] | Z3 |
| SW.ARV01.111 |  | Balance Construction of ARV 01 |  | 45d | 2014-04-12 | 2014-05-22 | SW.NCL01.111 | 105.5d | 0d | SSH-Construction Manhours [800 h] | Z3 |
| SW.NCL02.111 |  | Balance Construction of NCL02 |  | 30d | 2014-04-12 | 2014-05-08 | SW.NCL01.111 | 114.5d | 0d | SSH-Construction Manhours [800 h] | Z2 |
| SW.151 |  | Sand covering + trench backfilling + compaction-Along Rd 3 |  | 15d | 2014-04-26 | 2014-05-08 | SW.141, SW.150 | 180.5d | 15d | SSH-Construction Manhours [800 h] | Z3 |
| SW.ARV02.111 |  | Balance Construction of ARV 02 |  | 45d | 2014-04-26 | 2014-06-05 | SW.ARV01.111 SS+15d | 105.5d | 0d | SSH-Construction Manhours [800 h] | Z3 |
| SW.123 |  | Balance Pipe Installation - Along Road 1 Crossing |  | 35d | 2014-05-10 | 2014-06-10 | SW.122 | 145.5d | 0d | SSH-Construction Manhours [1000 h] | Z3 |
| SW.126 |  | Balance Pipe Installation - Along Road 3 Zone 4 |  | 35d | 2014-05-10 | 2014-06-10 | SW.125 | 135.5d | 10d | SSH-Construction Manhours [1000 h] | Z4 |
| SW.142 |  | Hydrotest - Along Road 5 |  | 15d | 2014-05-10 | 2014-05-22 | SW.122 | 165.5d | 0d | SSH-Construction Manhours [500 h] | Z3 |
| SW.144 |  | Hydrotest - Along Road 6 & 7 |  | 45d | 2014-05-10 | 2014-06-19 | SW.125, SW.124 | 95.5d | 0d | SSH-Construction Manhours [500 h] | Z2 |
| SW.ARV03.111 |  | Balance Construction of ARV 03 |  | 45d | 2014-05-10 | 2014-06-19 | SW.ARV02.111 SS+15d | 105.5d | 0d | SSH-Construction Manhours [800 h] | Z3 |
| SW.NCL03.111 |  | Balance Construction of NCL03 |  | 30d | 2014-05-10 | 2014-06-05 | SW.NCL02.111 | 114.5d | 0d | SSH-Construction Manhours [800 h] | Z2 |
| SW.152 |  | Sand covering + trench backfilling + compaction-Along Rd 5 |  | 15d | 2014-05-24 | 2014-06-05 | SW.142, SW.151 | 165.5d | 20d | SSH-Construction Manhours [800 h] | Z3 |
| SW.ARV04.111 |  | Balance Construction of ARV 04 |  | 45d | 2014-05-24 | 2014-07-03 | SW.150, SW.ARV03.111 SS+15d | 105.5d | 0d | SSH-Construction Manhours [800 h] | Z3 |
| SW.ARV05.111 |  | Balance Construction of ARV 05 |  | 45d | 2014-06-07 | 2014-07-17 | SW.ARV04.111 SS+15d | 105.5d | 0d | SSH-Construction Manhours [800 h] | Z3 |
| SW.NCL23.111 |  | Construction of NCL23 |  | 30d | 2014-06-07 | 2014-07-03 | RC.Z1.112, SW.NCL03.111 | 114.5d | 19d | SSH-Construction Manhours [800 h] | Z2 |
| SW.143 |  | Hydrotest - Along Road 1 |  | 15d | 2014-06-11 | 2014-06-24 | SW.123 | 145.5d | 0d | SSH-Construction Manhours [550 h] | Z3 |
| SW.145 |  | Hydrotest - Along Road 3 Zone 4 |  | 15d | 2014-06-21 | 2014-07-03 | SW.144, SW.126 | 125.5d | 30d | SSH-Construction Manhours [500 h] | Z4 |
| SW.154 |  | Sand covering + trench backfilling + compaction-Along Rd 6&7 |  | 45d | 2014-06-21 | 2014-07-31 | SW.144 | 95.5d | 0d | SSH-Construction Manhours [800 h] | Z2 |
| SW.ARV06.111 |  | Balance Construction of ARV 06 |  | 45d | 2014-06-21 | 2014-07-31 | SW.ARV05.111 SS+15d | 105.5d | 0d | SSH-Construction Manhours [800 h] | Z3 |
| SW.153 |  | Sand covering + trench backfilling + compaction-Along Rd 1 |  | 15d | 2014-06-25 | 2014-07-08 | SW.143, SW.152 | 145.5d | 50d | SSH-Construction Manhours [800 h] | Z3 |
| SW.ARV10.111 |  | Balance Construction of ARV 10 |  | 45d | 2014-07-05 | 2014-08-14 | SW.NCL24.111, SW.ARV06.111 SS+15d | 105.5d | 10d | SSH-Construction Manhours [800 h] | Z3 |
| SW.155 |  | Sand covering + trench backfilling + compaction-Along Rd 3Z4 |  | 25d | 2014-08-02 | 2014-08-24 | SW.154, SW.145 | 95.5d | 0d | SSH-Construction Manhours [800 h] | Z4 |
| SW.999 |  | Seawater Network Finish | milestone | 0d | 2014-08-24 | 2014-08-24 | SW.ARV10.111, SW.155, SW.151, SW.NCL24.111, SW.152, SW.153, SW.150, SW.145, SW.154 | 95.5d | 0d |  | Z3 |

| ID | WBS | Activity | Type | Duration | Start | Finish | Predecessors | Total float | Free float | Resources | Department |
| --- | --- | --- | --- | --- | --- | --- | --- | --- | --- | --- | --- |
|  | 6 | **Irrigation Network** |  |  | 2014-02-01 | 2014-07-31 |  |  |  |  |  |
| IRR.110 |  | Resolve Procurement & Engineering Issues |  | 30d | 2014-02-01 | 2014-02-27 | Eng.110 SS | 120.5d | 0d | SSH-Construction Manhours | MGT |
| IRR.125 |  | Balance Pipe Installation - Along Road 6 & 7 |  | 25d | 2014-02-01 | 2014-02-23 | RC.Z2.111 SS | 125.5d | 0d | SSH-Construction Manhours [500 h] | Z2 |
| IRR.120 |  | Balance Pipe Installation - Along Road 2 |  | 30d | 2014-02-15 | 2014-03-13 | IRR.110 SS+15d | 120.5d | 0d | SSH-Construction Manhours [400 h] | Z3 |
| IRR.126 |  | Balance Pipe Installation + Secondary lines - Along Road C & D |  | 45d | 2014-02-24 | 2014-04-06 | IRR.125 | 125.5d | 0d | SSH-Construction Manhours [1000 h] | Z2 |
| IRR.130 |  | Install Irrigation Valve Boxes - Along Road A |  | 30d | 2014-02-24 | 2014-03-23 | IRR.120 SS+10d | 125.5d | 0d | SSH-Construction Manhours [800 h] | Z3 |
| IRR.145 |  | Hydrotest - Along Road 6 & 7 |  | 30d | 2014-02-24 | 2014-03-23 | IRR.125 | 175.5d | 0d | SSH-Construction Manhours [800 h] | Z2 |
| IRR.121 |  | Balance Pipe Installation - Along Road 3 |  | 30d | 2014-03-15 | 2014-04-10 | IRR.120 | 120.5d | 0d | SSH-Construction Manhours [400 h] | Z3 |
| IRR.140 |  | Hydrotest - Along Road 2 |  | 20d | 2014-03-15 | 2014-04-01 | IRR.120 | 140.5d | 0d | SSH-Construction Manhours [500 h] | Z3 |
| IRR.131 |  | Install Irrigation Valve Boxes - Along Road B |  | 20d | 2014-03-24 | 2014-04-10 | IRR.130, IRR.121 SS+10d | 125.5d | 0d | SSH-Construction Manhours [500 h] | Z3 |
| IRR.155 |  | Sand covering + trench backfilling + compaction-Along Rd 6 & 7 |  | 30d | 2014-03-24 | 2014-04-20 | IRR.145 | 175.5d | 15d | SSH-Construction Manhours [800 h] | Z2 |
| IRR.150 |  | Sand covering + trench backfilling + compaction-Along Rd 2 |  | 20d | 2014-04-02 | 2014-04-20 | IRR.140 | 140.5d | 10d | SSH-Construction Manhours [800 h] | Z3 |
| IRR.127 |  | Balance Pipe Installation + Secondary lines - Along Road A & B |  | 45d | 2014-04-07 | 2014-05-18 | IRR.126 | 155.5d | 0d | SSH-Construction Manhours [1000 h] | Z3 |
| IRR.128 |  | Balance Pipe Installation - Line Towards Utility Plant |  | 45d | 2014-04-07 | 2014-05-18 | IRR.126 | 125.5d | 0d | SSH-Construction Manhours [1000 h] | Z2 |
| IRR.146 |  | Hydrotest - Along Road C & D |  | 30d | 2014-04-07 | 2014-05-04 | IRR.126 | 160.5d | 0d | SSH-Construction Manhours [800 h] | Z2 |
| IRR.122 |  | Balance Pipe Installation - Along Road 5 |  | 30d | 2014-04-12 | 2014-05-08 | IRR.121 | 120.5d | 0d | SSH-Construction Manhours [400 h] | Z3 |
| IRR.132 |  | Install Irrigation Valve Boxes - Along Road C |  | 30d | 2014-04-12 | 2014-05-08 | IRR.131 | 125.5d | 0d | SSH-Construction Manhours [800 h] | Z2 |
| IRR.141 |  | Hydrotest - Along Road 3 |  | 20d | 2014-04-12 | 2014-04-29 | IRR.131, IRR.121, IRR.130 | 130.5d | 0d | SSH-Construction Manhours [500 h] | Z3 |
| IRR.151 |  | Sand covering + trench backfilling + compaction-Along Rd 3 |  | 20d | 2014-04-30 | 2014-05-18 | IRR.150, IRR.141 | 130.5d | 10d | SSH-Construction Manhours [800 h] | Z3 |
| IRR.156 |  | Sand covering + trench backfilling + compaction-Along Rd C & D |  | 30d | 2014-05-05 | 2014-06-01 | IRR.146, IRR.155 | 160.5d | 5d | SSH-Construction Manhours [800 h] | Z2 |
| IRR.123 |  | Balance Pipe Installation - Along Road 1 |  | 25d | 2014-05-10 | 2014-06-01 | IRR.122 | 120.5d | 0d | SSH-Construction Manhours [400 h] | Z3 |
| IRR.133 |  | Install Irrigation Valve Boxes - Along Road D |  | 20d | 2014-05-10 | 2014-05-27 | IRR.132 | 125.5d | 5d | SSH-Construction Manhours [500 h] | Z2 |
| IRR.142 |  | Hydrotest - Along Road 5 |  | 20d | 2014-05-10 | 2014-05-27 | IRR.122 | 120.5d | 0d | SSH-Construction Manhours [500 h] | Z3 |
| IRR.147 |  | Hydrotest - Along Road A & B |  | 20d | 2014-05-19 | 2014-06-05 | IRR.127 | 155.5d | 0d | SSH-Construction Manhours [800 h] | Z3 |
| IRR.148 |  | Hydrotest - Line towards Utility Plant |  | 30d | 2014-05-19 | 2014-06-15 | IRR.128 | 125.5d | 0d | SSH-Construction Manhours [1200 h] | Z2 |
| IRR.152 |  | Sand covering + trench backfilling + compaction-Along Rd 5 |  | 25d | 2014-05-28 | 2014-06-19 | IRR.142, IRR.151 | 120.5d | 0d | SSH-Construction Manhours [800 h] | Z3 |
| IRR.124 |  | Balance Pipe Installation - Along Road 4 |  | 20d | 2014-06-02 | 2014-06-19 | IRR.123 | 130.5d | 0d | SSH-Construction Manhours [300 h] | Z3 |
| IRR.143 |  | Hydrotest - Along Road 1 |  | 20d | 2014-06-02 | 2014-06-19 | IRR.133, IRR.123, IRR.132 | 120.5d | 0d | SSH-Construction Manhours [500 h] | Z3 |
| IRR.157 |  | Sand covering + trench backfilling + compaction-Along Rd A & B |  | 25d | 2014-06-07 | 2014-06-29 | IRR.156, IRR.147 | 155.5d | 35d | SSH-Construction Manhours [800 h] | Z3 |
| IRR.158 |  | Sand covering + trench backfilling + compaction-towards utility plant |  | 45d | 2014-06-16 | 2014-07-27 | IRR.148, SW.NCL03.111 | 125.5d | 5d | SSH-Construction Manhours [2000 h] | Z2 |
| IRR.144 |  | Hydrotest - Along Road 4 |  | 15d | 2014-06-21 | 2014-07-03 | IRR.133, IRR.124 | 130.5d | 10d | SSH-Construction Manhours [300 h] | Z3 |
| IRR.153 |  | Sand covering + trench backfilling + compaction-Along Rd 1 |  | 25d | 2014-06-21 | 2014-07-13 | IRR.143, IRR.152 | 120.5d | 0d | SSH-Construction Manhours [800 h] | Z3 |
| IRR.154 |  | Sand covering + trench backfilling + compaction-Along Rd 4 |  | 20d | 2014-07-14 | 2014-07-31 | IRR.144, IRR.153 | 120.5d | 0d | SSH-Construction Manhours [800 h] | Z3 |
| IRR.999 |  | Irrigation Network Finish | milestone | 0d | 2014-07-31 | 2014-07-31 | IRR.157, IRR.150, IRR.158, IRR.153, IRR.151, IRR.154 | 120.5d | 0d |  | Z3 |

| ID | WBS | Activity | Type | Duration | Start | Finish | Predecessors | Total float | Free float | Resources | Department |
| --- | --- | --- | --- | --- | --- | --- | --- | --- | --- | --- | --- |
|  | 7 | **Gravity Sewer & Force Mainline** |  |  | 2014-02-15 | 2014-09-11 |  |  |  |  |  |
| GFL.120 |  | Balance work of Force line in zone 3 |  | 45d | 2014-02-15 | 2014-03-27 | Eng.110 SS+15d | 5.5d | 0d | SSH-Construction Manhours [2500 h] | Z3 |
| GFL.SD01.111 |  | Balance Construction of slow down chamber 01 |  | 50d | 2014-02-15 | 2014-04-01 | GFL.120 SS | 5.5d | 0d | SSH-Construction Manhours [2000 h] | Z3 |
| GSL.111 |  | Excavation for Gravity Sewer Line Installation along road 2 zone 4 |  | 30d | 2014-02-15 | 2014-03-13 | GFL.120 SS | 5.5d | 0d | SSH-Construction Manhours [800 h] | Z4 |
| GFL.121 |  | Balance work of Force line in zone 2 |  | 45d | 2014-02-24 | 2014-04-06 | GFL.120 SS+10d | 50.5d | 5d | SSH-Construction Manhours [2500 h] | Z2 |
| GFL.SD02.111 |  | Balance Construction of slow down chamber 02 |  | 50d | 2014-03-05 | 2014-04-20 | GFL.SD01.111 SS+20d | 5.5d | 0d | SSH-Construction Manhours [2000 h] | Z3 |
| GSL.112 |  | Balance Gravity Sewer Line Installation along road 2 zone 4 |  | 30d | 2014-03-15 | 2014-04-10 | GSL.111 | 5.5d | 0d | SSH-Construction Manhours [1500 h] | Z4 |
| GFL.WC01.111 |  | Balance Construction of wash chamber 01 |  | 50d | 2014-03-24 | 2014-05-08 | GFL.SD02.111 SS+20d | 5.5d | 0d | SSH-Construction Manhours [800 h] | Z2 |
| GFL.130 |  | Hydrotesting Zone 3 |  | 45d | 2014-03-29 | 2014-05-08 | GFL.120 | 45.5d | 0d | SSH-Construction Manhours [1500 h] | Z3 |
| GFL.140 |  | Hydrotesting Zone 2 |  | 45d | 2014-04-12 | 2014-05-22 | GFL.130 SS+15d, GFL.121 | 60.5d | 0d | SSH-Construction Manhours [800 h] | Z2 |
| GFL.WC02.111 |  | Balance Construction of wash chamber 02 |  | 50d | 2014-04-12 | 2014-05-27 | GFL.WC01.111 SS+20d | 5.5d | 0d | SSH-Construction Manhours [800 h] | Z2 |
| GSL.113 |  | Leakage Gravity Test for Gravity Sewer Line road 2 Zoen 4 |  | 30d | 2014-04-12 | 2014-05-08 | GSL.112 | 5.5d | 0d | SSH-Construction Manhours [800 h] | Z4 |
| GFL.WDV01.111 |  | Balance Construction of WDV01 |  | 50d | 2014-04-30 | 2014-06-15 | GFL.WC02.111 SS+20d | 5.5d | 0d | SSH-Construction Manhours [2000 h] | Z3 |
| GFL.150 |  | Sand covering + trench backfilling + compaction Zone 3 |  | 45d | 2014-05-10 | 2014-06-19 | GFL.140 SS, GSL.114 SS, GFL.130 | 45.5d | 40d | SSH-Construction Manhours [1500 h] | Z3 |
| GSL.114 |  | Backfilling for Gravity Sewer Line road 2 Zoen 4 |  | 30d | 2014-05-10 | 2014-06-05 | GSL.113 | 5.5d | 0d | SSH-Construction Manhours [1000 h] | Z4 |
| GFL.WDV02.111 |  | Balance Construction of WDV02 |  | 50d | 2014-05-19 | 2014-07-03 | GFL.WDV01.111 SS+20d, GFL.121 | 5.5d | 0d | SSH-Construction Manhours [2000 h] | Z3 |
| GFL.160 |  | Sand covering + trench backfilling + compaction Zone 2 |  | 45d | 2014-05-24 | 2014-07-03 | GFL.140 | 80.5d | 75d |  | Z2 |
| GFL.WDV03.111 |  | Balance Construction of WDV03 |  | 50d | 2014-06-07 | 2014-07-22 | GSL.114, GFL.WDV02.111 SS+20d | 5.5d | 0d | SSH-Construction Manhours [2000 h] | Z3 |
| GFL.WDV04.111 |  | Balance Construction of WDV04 |  | 50d | 2014-06-25 | 2014-08-10 | GFL.WDV03.111 SS+20d | 5.5d | 0d | SSH-Construction Manhours [2000 h] | Z3 |
| GFL.WDV05.111 |  | Balance Construction of WDV05 |  | 50d | 2014-07-14 | 2014-08-28 | GFL.140, GFL.WDV04.111 SS+20d | 5.5d | 0d | SSH-Construction Manhours [2000 h] | Z3 |
| GFL.WDV06.111 |  | Balance Construction of WDV06 |  | 50d | 2014-07-28 | 2014-09-11 | GFL.150, GFL.WDV05.111 SS+15d | 5.5d | 0d | SSH-Construction Manhours [2000 h] | Z3 |
| GFL.999 |  | Sewer Network Finish | milestone | 0d | 2014-09-11 | 2014-09-11 | GFL.150, GSL.114, GFL.WDV06.111, GFL.160 | 5.5d | 0d |  | Z3 |
|  | 8 | **Lift Station - 9** |  |  | 2014-02-01 | 2014-11-16 |  |  |  |  |  |
| LS9.110 |  | Backfilling |  | 30d | 2014-02-01 | 2014-02-27 | Eng.110 SS | 11.5d | 0d | SSH-Construction Manhours [1600 h] | Z4 |
| LS9.120 |  | Surface Preparation |  | 20d | 2014-03-01 | 2014-03-18 | LS9.110 | 11.5d | 0d | SSH-Construction Manhours [800 h] | Z4 |
| LS9.130 |  | Painting |  | 15d | 2014-03-19 | 2014-04-01 | LS9.120 | 11.5d | 0d | SSH-Construction Manhours [800 h] | Z4 |
| LS9.140 |  | Access cover |  | 10d | 2014-04-02 | 2014-04-10 | LS9.130 | 11.5d | 0d | SSH-Construction Manhours [500 h] | Z4 |
| LS9.510 |  | Excavation for electric room |  | 15d | 2014-04-02 | 2014-04-15 | LS9.140 SS | 11.5d | 0d | SSH-Construction Manhours [800 h] | Z4 |
| LS9.170 |  | Piping System |  | 25d | 2014-04-12 | 2014-05-04 | LS9.140, LS9.130 | 18.5d | 0d | SSH-Construction Manhours [100 h] | Z4 |
| LS9.520 |  | Lean concrete for electric room |  | 10d | 2014-04-16 | 2014-04-24 | LS9.510 | 11.5d | 0d | SSH-Construction Manhours [1000 h] | Z4 |
| LS9.530 |  | Grade beam for electric room |  | 21d | 2014-04-26 | 2014-05-14 | LS9.520 | 11.5d | 0d | SSH-Construction Manhours [2000 h] | Z4 |
| LS9.180 |  | Cabling system |  | 25d | 2014-05-05 | 2014-05-27 | LS9.170 | 18.5d | 0d | SSH-Construction Manhours [800 h] | Z4 |
| LS9.200 |  | Odour control system |  | 20d | 2014-05-05 | 2014-05-22 | LS9.170 | 50.5d | 0d | SSH-Construction Manhours [1200 h] | Z4 |
| LS9.540 |  | Grade columns for electric room |  | 21d | 2014-05-14 | 2014-06-03 | LS9.530 | 11.5d | 0d | SSH-Construction Manhours [2000 h] | Z4 |
| LS9.210 |  | Fire alarm system |  | 20d | 2014-05-24 | 2014-06-10 | LS9.200 | 50.5d | 0d | SSH-Construction Manhours [1200 h] | Z4 |
| LS9.190 |  | Instrumentation system |  | 25d | 2014-05-28 | 2014-06-19 | LS9.180 SS+15d, LS9.180 | 18.5d | 7d | SSH-Construction Manhours [2000 h] | Z4 |
| LS9.550 |  | Roof slab for electric room |  | 21d | 2014-06-03 | 2014-06-23 | LS9.540, LS9.190 SS | 11.5d | 0d | SSH-Construction Manhours [2000 h] | Z4 |
| LS9.220 |  | Electrical system |  | 20d | 2014-06-11 | 2014-06-29 | LS9.210 | 50.5d | 0d | SSH-Construction Manhours [1200 h] | Z4 |
| LS9.560 |  | Block works for electric room |  | 21d | 2014-06-17 | 2014-07-07 | LS9.550 SS+15d | 11.5d | 0d | SSH-Construction Manhours [1200 h] | Z4 |
| LS9.221 |  | Ventilation sytem |  | 20d | 2014-06-30 | 2014-07-17 | LS9.220 | 50.5d | 0d | SSH-Construction Manhours [800 h] | Z4 |
| LS9.570 |  | Floor slab for electric room |  | 21d | 2014-07-07 | 2014-07-27 | LS9.550, LS9.560 | 11.5d | 0d | SSH-Construction Manhours [1600 h] | Z4 |
| LS9.222 |  | Generator Installation |  | 15d | 2014-07-19 | 2014-07-31 | LS9.221 | 50.5d | 45d | SSH-Construction Manhours [600 h] | Z4 |
| LS9.580 |  | Plastering of Electric room |  | 15d | 2014-07-27 | 2014-08-10 | LS9.570 | 11.5d | 0d | SSH-Construction Manhours [1200 h] | Z4 |
| LS9.590 |  | Painting of Electric room |  | 10d | 2014-08-10 | 2014-08-19 | LS9.580 | 11.5d | 0d | SSH-Construction Manhours [800 h] | Z4 |
| LS9.600 |  | Electric system in electric room |  | 15d | 2014-08-19 | 2014-09-02 | LS9.590 | 11.5d | 0d | SSH-Construction Manhours [2000 h] | Z4 |
| LS9.610 |  | Equipment installation in electric room |  | 15d | 2014-09-02 | 2014-09-16 | LS9.600 | 11.5d | 0d | SSH-Construction Manhours [1200 h] | Z4 |
| LS9.150 |  | Install Precast Fence & gate |  | 25d | 2014-09-13 | 2014-10-05 | GFL.999, LS9.222, LS9.590, LS9.140 SS | 5.5d | 0d | SSH-Construction Manhours [1600 h] | Z4 |
| LS9.230 |  | Testing & Pre-commissioning |  | 30d | 2014-09-16 | 2014-10-14 | LS9.610, LS9.220, LS9.222, LS9.600 | 11.5d | 6d | SSH-Construction Manhours [1200 h] | Z4 |
| LS9.160 |  | Asphalt pavement |  | 15d | 2014-10-06 | 2014-10-19 | LS9.150 | 5.5d | 0d | SSH-Construction Manhours [1200 h] | Z4 |
| LS9.240 |  | Commissioning & Tie in |  | 30d | 2014-10-20 | 2014-11-16 | LS9.160, LS9.230 | 5.5d | 0d | SSH-Construction Manhours [600 h] | Z4 |
| LS9.999 |  | Lift Station 9 Finish | milestone | 0d | 2014-11-16 | 2014-11-16 | LS9.160, LS9.190, LS9.610, LS9.240 | 5.5d | 4d |  | Z4 |

| ID | WBS | Activity | Type | Duration | Start | Finish | Predecessors | Total float | Free float | Resources | Department |
| --- | --- | --- | --- | --- | --- | --- | --- | --- | --- | --- | --- |
|  | 9 | **Lift Station - 10** |  |  | 2014-02-01 | 2014-11-20 |  |  |  |  |  |
| LS10.110 |  | Backfilling |  | 20d | 2014-02-01 | 2014-02-18 | Eng.110 SS | 1.5d | 0d | SSH-Construction Manhours [1600 h] | Z3 |
| LS10.120 |  | Surface Preparation |  | 15d | 2014-02-19 | 2014-03-04 | LS10.110 | 1.5d | 0d | SSH-Construction Manhours [800 h] | Z3 |
| LS10.122 |  | Floor slab |  | 25d | 2014-03-05 | 2014-03-27 | LS10.120 | 1.5d | 0d | SSH-Construction Manhours [1200 h] | Z3 |
| LS10.123 |  | Roof water proofing system |  | 15d | 2014-03-29 | 2014-04-10 | LS10.122 | 1.5d | 0d | SSH-Construction Manhours [600 h] | Z3 |
| LS10.124 |  | FRP Ladder |  | 10d | 2014-04-12 | 2014-04-20 | LS10.122, LS10.123 | 1.5d | 0d | SSH-Construction Manhours [400 h] | Z3 |
| LS10.510 |  | Excavation for electric room |  | 15d | 2014-04-12 | 2014-04-24 | LS10.124 SS | 1.5d | 0d | SSH-Construction Manhours [800 h] | Z3 |
| LS10.130 |  | Painting |  | 15d | 2014-04-21 | 2014-05-04 | LS10.124 | 25.5d | 0d | SSH-Construction Manhours [800 h] | Z3 |
| LS10.520 |  | Lean concrete for electric room |  | 10d | 2014-04-26 | 2014-05-04 | LS10.510 | 1.5d | 0d | SSH-Construction Manhours [500 h] | Z3 |
| LS10.140 |  | Door & access cover |  | 10d | 2014-05-05 | 2014-05-13 | LS10.130 | 25.5d | 0d | SSH-Construction Manhours [500 h] | Z3 |
| LS10.530 |  | Grade beam for electric room |  | 21d | 2014-05-05 | 2014-05-24 | LS10.520 | 1.5d | 0d | SSH-Construction Manhours [2000 h] | Z3 |
| LS10.170 |  | Piping System |  | 25d | 2014-05-14 | 2014-06-05 | LS10.140, LS10.130 | 25.5d | 0d | SSH-Construction Manhours [800 h] | Z3 |
| LS10.540 |  | Grade columns for electric room |  | 21d | 2014-05-24 | 2014-06-12 | LS10.530 | 1.5d | 0d | SSH-Construction Manhours [2000 h] | Z3 |
| LS10.180 |  | Cabling system |  | 25d | 2014-05-28 | 2014-06-19 | LS10.170 SS+15d | 30.5d | 0d | SSH-Construction Manhours [2000 h] | Z3 |
| LS10.171 |  | Monorail crane |  | 15d | 2014-06-07 | 2014-06-19 | LS10.170 | 30.5d | 5d | SSH-Construction Manhours [1000 h] | Z3 |
| LS10.200 |  | Odour control system |  | 20d | 2014-06-07 | 2014-06-24 | LS10.170 | 25.5d | 0d | SSH-Construction Manhours [1200 h] | Z3 |
| LS10.190 |  | Instrumentation system |  | 25d | 2014-06-11 | 2014-07-03 | LS10.180 SS+15d | 35.5d | 10d | SSH-Construction Manhours [800 h] | Z3 |
| LS10.550 |  | Roof slab for electric room |  | 21d | 2014-06-12 | 2014-07-02 | LS10.540 | 1.5d | 0d | SSH-Construction Manhours [2000 h] | Z3 |
| LS10.210 |  | Fire alarm system |  | 20d | 2014-06-25 | 2014-07-13 | LS10.180, LS10.200, LS10.171 | 25.5d | 0d | SSH-Construction Manhours [1200 h] | Z3 |
| LS10.560 |  | Block works for electric room |  | 21d | 2014-06-26 | 2014-07-16 | LS10.550 SS+15d | 1.5d | 0d | SSH-Construction Manhours [1200 h] | Z3 |
| LS10.220 |  | Electrical system |  | 20d | 2014-07-14 | 2014-07-31 | LS10.210, LS10.190 | 25.5d | 0d | SSH-Construction Manhours [1200 h] | Z3 |
| LS10.570 |  | Floor slab for electric room |  | 21d | 2014-07-16 | 2014-08-05 | LS10.550, LS10.560 | 1.5d | 0d | SSH-Construction Manhours [1600 h] | Z3 |
| LS10.221 |  | Ventilation sytem |  | 20d | 2014-08-02 | 2014-08-19 | LS10.220 | 25.5d | 0d | SSH-Construction Manhours [800 h] | Z3 |
| LS10.580 |  | Plastering of Electric room |  | 15d | 2014-08-05 | 2014-08-19 | LS10.570 | 1.5d | 0d | SSH-Construction Manhours [1200 h] | Z3 |
| LS10.590 |  | Painting of Electric room |  | 10d | 2014-08-19 | 2014-08-28 | LS10.580 | 1.5d | 0d | SSH-Construction Manhours [800 h] | Z3 |
| LS10.222 |  | Generator Installation |  | 15d | 2014-08-20 | 2014-09-02 | LS10.221 | 25.5d | 24d | SSH-Construction Manhours [600 h] | Z3 |
| LS10.150 |  | Install Precast Fence & gate |  | 25d | 2014-08-28 | 2014-09-21 | LS10.140 SS, LS10.590, LS10.124 | 51.5d | 0d | SSH-Construction Manhours [1600 h] | Z3 |
| LS10.600 |  | Electric system in electric room |  | 15d | 2014-08-28 | 2014-09-11 | LS10.590 | 1.5d | 0d | SSH-Construction Manhours [2000 h] | Z3 |
| LS10.610 |  | Equipment installation in electric room |  | 15d | 2014-09-11 | 2014-09-25 | LS10.600 | 1.5d | 0d | SSH-Construction Manhours [1200 h] | Z3 |
| LS10.160 |  | Asphalt pavement |  | 15d | 2014-09-21 | 2014-10-05 | LS10.150 | 51.5d | 50d | SSH-Construction Manhours [1200 h] | Z3 |
| LS10.230 |  | Testing & Pre-commissioning |  | 30d | 2014-09-25 | 2014-10-23 | LS10.222, LS10.220, LS10.610, LS10.600 | 1.5d | 0d | SSH-Construction Manhours [1200 h] | Z3 |
| LS10.240 |  | Commissioning & Tie in |  | 30d | 2014-10-23 | 2014-11-20 | LS10.230 | 1.5d | 0d | SSH-Construction Manhours [600 h] | Z3 |
| LS10.999 |  | Lift Station 10 Finish | milestone | 0d | 2014-11-20 | 2014-11-20 | LS10.190, LS10.240, LS10.171, LS10.160, LS10.610, Z2.999 | 1.5d | 0d |  | Z3 |

| ID | WBS | Activity | Type | Duration | Start | Finish | Predecessors | Total float | Free float | Resources | Department |
| --- | --- | --- | --- | --- | --- | --- | --- | --- | --- | --- | --- |
|  | 10 | **Lift Station - 11** |  |  | 2014-02-01 | 2014-11-08 |  |  |  |  |  |
| LS11.110 |  | Backfilling |  | 20d | 2014-02-01 | 2014-02-18 | Eng.110 SS | -0.5d | 0d | SSH-Construction Manhours [1600 h] | Z3 |
| LS11.120 |  | Surface preparation |  | 20d | 2014-02-19 | 2014-03-09 | LS11.110 | 14.5d | 0d | SSH-Construction Manhours [800 h] | Z3 |
| LS11.130 |  | Painting |  | 15d | 2014-03-10 | 2014-03-23 | LS11.120 | 14.5d | 0d | SSH-Construction Manhours [800 h] | Z3 |
| LS11.140 |  | Access cover |  | 10d | 2014-03-24 | 2014-04-01 | LS11.130 | 14.5d | 0d | SSH-Construction Manhours [500 h] | Z3 |
| LS11.170 |  | Piping System |  | 25d | 2014-04-02 | 2014-04-24 | LS11.130, LS11.140 | 60.5d | 0d | SSH-Construction Manhours [800 h] | Z3 |
| LS11.510 |  | Excavation for electric room |  | 15d | 2014-04-02 | 2014-04-15 | LS11.140 | 14.5d | 0d | SSH-Construction Manhours [800 h] | Z3 |
| LS11.520 |  | Lean concrete for electric room |  | 10d | 2014-04-16 | 2014-04-24 | LS11.510 | 14.5d | 0d | SSH-Construction Manhours [500 h] | Z3 |
| LS11.180 |  | Cabling system |  | 25d | 2014-04-26 | 2014-05-18 | LS11.170 | 60.5d | 0d | SSH-Construction Manhours [800 h] | Z3 |
| LS11.200 |  | Odour control system |  | 20d | 2014-04-26 | 2014-05-13 | LS11.170 | 60.5d | 0d | SSH-Construction Manhours [1200 h] | Z3 |
| LS11.530 |  | Grade beam for electric room |  | 25d | 2014-04-26 | 2014-05-18 | LS11.520 | 14.5d | 0d | SSH-Construction Manhours [2000 h] | Z3 |
| LS11.190 |  | Instrumentation system |  | 25d | 2014-05-10 | 2014-06-01 | LS11.180 SS+15d | 60.5d | 0d | SSH-Construction Manhours [2000 h] | Z3 |
| LS11.210 |  | Fire alarm system |  | 20d | 2014-05-14 | 2014-06-01 | LS11.200 | 60.5d | 0d | SSH-Construction Manhours [1200 h] | Z3 |
| LS11.540 |  | Grade columns for electric room |  | 25d | 2014-05-19 | 2014-06-10 | LS11.530 | 14.5d | 0d | SSH-Construction Manhours [2000 h] | Z3 |
| LS11.220 |  | Electrical system |  | 20d | 2014-06-02 | 2014-06-19 | LS11.180, LS11.190, LS11.210 | 60.5d | 0d | SSH-Construction Manhours [1200 h] | Z3 |
| LS11.550 |  | Roof slab for electric room |  | 25d | 2014-06-11 | 2014-07-03 | LS11.540 | 14.5d | 0d | SSH-Construction Manhours [2000 h] | Z3 |
| LS11.560 |  | Block works for electric room |  | 25d | 2014-06-11 | 2014-07-03 | LS11.550 SS | 14.5d | 0d | SSH-Construction Manhours [1200 h] | Z3 |
| LS11.221 |  | Ventilation system |  | 20d | 2014-06-21 | 2014-07-08 | LS11.220 | 60.5d | 0d | SSH-Construction Manhours [800 h] | Z3 |
| LS11.570 |  | Floor slab for electric room |  | 21d | 2014-07-05 | 2014-07-23 | LS11.560, LS11.550 | 14.5d | 0d | SSH-Construction Manhours [1600 h] | Z3 |
| LS11.222 |  | Generator installation |  | 15d | 2014-07-09 | 2014-07-22 | LS11.221 | 60.5d | 26d | SSH-Construction Manhours [600 h] | Z3 |
| LS11.580 |  | Plastering of Electric room |  | 15d | 2014-07-23 | 2014-08-06 | LS11.570 | 14.5d | 0d | SSH-Construction Manhours [1200 h] | Z3 |
| LS11.590 |  | Painting of Electric room |  | 10d | 2014-08-06 | 2014-08-16 | LS11.580 | 14.5d | 0d | SSH-Construction Manhours [800 h] | Z3 |
| LS11.150 |  | Install Precast Fence & gate |  | 25d | 2014-08-16 | 2014-09-08 | LS11.222, LS11.590, LS11.140 SS | 34.5d | 0d | SSH-Construction Manhours [1600 h] | Z3 |
| LS11.600 |  | Electric system in electric room |  | 15d | 2014-08-16 | 2014-08-30 | LS11.590 | 14.5d | 0d | SSH-Construction Manhours [2000 h] | Z3 |
| LS11.610 |  | Equipment installation in electric room |  | 15d | 2014-08-30 | 2014-09-13 | LS11.600 | 14.5d | 0d | SSH-Construction Manhours [1200 h] | Z3 |
| LS11.160 |  | Asphalt pavement |  | 15d | 2014-09-08 | 2014-09-22 | LS11.150 | 34.5d | 20d | SSH-Construction Manhours [1200 h] | Z3 |
| LS11.230 |  | Testing & Pre-commissioning |  | 30d | 2014-09-13 | 2014-10-11 | LS11.610, LS11.600, LS11.222, LS11.220 | 14.5d | 0d | SSH-Construction Manhours [1200 h] | Z3 |
| LS11.240 |  | Commissioning & Tie in |  | 30d | 2014-10-11 | 2014-11-08 | LS11.230, LS11.160 | 14.5d | 0d | SSH-Construction Manhours [600 h] | Z3 |
| LS11.999 |  | Lift station 11 finish | milestone | 0d | 2014-11-08 | 2014-11-08 | LS11.240, LS11.190, LS11.160, LS11.610 | 14.5d | 13d |  | Z3 |

| ID | WBS | Activity | Type | Duration | Start | Finish | Predecessors | Total float | Free float | Resources | Department |
| --- | --- | --- | --- | --- | --- | --- | --- | --- | --- | --- | --- |
|  | 11 | **Lift Station - 12** |  |  | 2014-02-01 | 2014-09-30 |  |  |  |  |  |
| LS12.040 |  | Retaining walls |  | 30d | 2014-02-01 | 2014-02-27 | RC.Z2.111 SS | 56.5d | 0d | SSH-Construction Manhours [2500 h] | Z2 |
| LS12.050 |  | Leak test |  | 15d | 2014-03-01 | 2014-03-13 | LS12.040 | 56.5d | 0d | SSH-Construction Manhours [1200 h] | Z2 |
| LS12.060 |  | Water proofing |  | 15d | 2014-03-15 | 2014-03-27 | LS12.050 | 56.5d | 0d | SSH-Construction Manhours [1200 h] | Z2 |
| LS12.070 |  | Top cover |  | 30d | 2014-03-29 | 2014-04-24 | LS12.060 | 56.5d | 0d | SSH-Construction Manhours [600 h] | Z2 |
| LS12.110 |  | Backfilling |  | 20d | 2014-03-29 | 2014-04-15 | LS12.070 SS | 56.5d | 0d | SSH-Construction Manhours [800 h] | Z2 |
| LS12.120 |  | Surface preparation |  | 20d | 2014-03-29 | 2014-04-15 | LS12.110 SS | 56.5d | 0d | SSH-Construction Manhours [800 h] | Z2 |
| LS12.510 |  | Excavation for electric room |  | 6d | 2014-03-29 | 2014-04-02 | LS12.120 SS | 56.5d | 0d | SSH-Construction Manhours [800 h] | Z2 |
| LS12.520 |  | Lean concrete for electric room |  | 6d | 2014-04-02 | 2014-04-08 | LS12.510 | 56.5d | 0d | SSH-Construction Manhours [500 h] | Z2 |
| LS12.530 |  | Grade beam for electric room |  | 15d | 2014-04-08 | 2014-04-22 | LS12.520 | 56.5d | 0d | SSH-Construction Manhours [800 h] | Z2 |
| LS12.130 |  | Painting |  | 15d | 2014-04-16 | 2014-04-29 | LS12.120 | 60.5d | 0d | SSH-Construction Manhours [800 h] | Z2 |
| LS12.540 |  | Grade columns for electric room |  | 21d | 2014-04-22 | 2014-05-12 | LS12.530 | 56.5d | 0d | SSH-Construction Manhours [1000 h] | Z2 |
| LS12.140 |  | Door & access cover |  | 10d | 2014-04-30 | 2014-05-08 | LS12.130 | 60.5d | 0d | SSH-Construction Manhours [500 h] | Z2 |
| LS12.141 |  | FRP ladder |  | 10d | 2014-05-10 | 2014-05-18 | LS12.140 | 80.5d | 15d | SSH-Construction Manhours [400 h] | Z2 |
| LS12.170 |  | Piping System |  | 25d | 2014-05-10 | 2014-06-01 | LS12.140, LS12.130 | 60.5d | 0d | SSH-Construction Manhours [800 h] | Z2 |
| LS12.550 |  | Roof slab for electric room |  | 21d | 2014-05-12 | 2014-06-01 | LS12.540 | 56.5d | 0d | SSH-Construction Manhours [2000 h] | Z2 |
| LS12.180 |  | Cabling system |  | 25d | 2014-05-24 | 2014-06-15 | LS12.170 SS+15d | 65.5d | 0d | SSH-Construction Manhours [2000 h] | Z2 |
| LS12.560 |  | Block works for electric room |  | 15d | 2014-05-26 | 2014-06-09 | LS12.550 SS+15d | 56.5d | 0d | SSH-Construction Manhours [1200 h] | Z2 |
| LS12.171 |  | Monorail crane |  | 15d | 2014-06-02 | 2014-06-15 | LS12.170, LS12.141 | 65.5d | 5d | SSH-Construction Manhours [1000 h] | Z2 |
| LS12.200 |  | Odour control system |  | 20d | 2014-06-02 | 2014-06-19 | LS12.170 | 60.5d | 0d | SSH-Construction Manhours [1200 h] | Z2 |
| LS12.190 |  | Instrumentation system |  | 25d | 2014-06-07 | 2014-06-29 | LS12.180 SS+15d | 65.5d | 5d | SSH-Construction Manhours [2000 h] | Z2 |
| LS12.570 |  | Floor slab for electric room |  | 21d | 2014-06-09 | 2014-06-29 | LS12.550, LS12.560 | 56.5d | 0d | SSH-Construction Manhours [1600 h] | Z2 |
| LS12.210 |  | Fire alarm system |  | 15d | 2014-06-21 | 2014-07-03 | LS12.180, LS12.200, LS12.171 | 60.5d | 0d | SSH-Construction Manhours [1200 h] | Z2 |
| LS12.580 |  | Plastering of Electric room |  | 15d | 2014-06-29 | 2014-07-13 | LS12.570 | 56.5d | 0d | SSH-Construction Manhours [1200 h] | Z2 |
| LS12.220 |  | Electrical system |  | 15d | 2014-07-05 | 2014-07-17 | LS12.210, LS12.190 | 60.5d | 0d | SSH-Construction Manhours [1200 h] | Z2 |
| LS12.590 |  | Painting of Electric room |  | 10d | 2014-07-13 | 2014-07-22 | LS12.580 | 56.5d | 0d | SSH-Construction Manhours [800 h] | Z2 |
| LS12.221 |  | Ventilation sytem |  | 15d | 2014-07-19 | 2014-07-31 | LS12.220 | 60.5d | 0d | SSH-Construction Manhours [800 h] | Z2 |
| LS12.150 |  | Install Precast Fence & gate |  | 21d | 2014-07-22 | 2014-08-10 | LS12.141, LS12.590, SW.NCL23.111 | 95.5d | 0d | SSH-Construction Manhours [1600 h] | Z2 |
| LS12.600 |  | Electric system in electric room |  | 15d | 2014-07-22 | 2014-08-05 | LS12.590 | 56.5d | 0d | SSH-Construction Manhours [2000 h] | Z2 |
| LS12.222 |  | Generator installation |  | 15d | 2014-08-02 | 2014-08-14 | LS12.221 | 60.5d | 4d | SSH-Construction Manhours [600 h] | Z2 |
| LS12.610 |  | Equipment installation in electric room |  | 15d | 2014-08-05 | 2014-08-19 | LS12.600 | 56.5d | 0d | SSH-Construction Manhours [1200 h] | Z2 |
| LS12.160 |  | Asphalt pavement |  | 15d | 2014-08-11 | 2014-08-24 | LS12.150 | 95.5d | 39d | SSH-Construction Manhours [1200 h] | Z2 |
| LS12.230 |  | Testing & Pre-commissioning |  | 30d | 2014-08-19 | 2014-09-16 | LS12.220, LS12.610, LS12.222, LS12.600 | 56.5d | 0d | SSH-Construction Manhours [2400 h] | Z2 |
| LS12.240 |  | Commissioning & Tie in |  | 30d | 2014-09-02 | 2014-09-30 | LS12.230 SS+15d | 56.5d | 0d | SSH-Construction Manhours [2400 h] | Z2 |
| LS12.999 |  | Lift Station 12 Finish | milestone | 0d | 2014-09-30 | 2014-09-30 | LS12.190, LS12.610, LS12.240, LS12.160, LS12.070, LS12.171 | 56.5d | 1d |  | Z2 |

| ID | WBS | Activity | Duration | Start | Finish | Predecessors | Total float | Free float | Resources | Department |
| --- | --- | --- | --- | --- | --- | --- | --- | --- | --- | --- |
|  | 12 | **Storm Drainage System** |  | 2014-02-01 | 2014-12-01 |  |  |  |  |  |
| SD.01.100 |  | Resolve Procurement & Engineering Issues | 30d | 2014-02-01 | 2014-02-27 | Eng.110 SS | -0.5d | 0d |  | MGT |
| SD.16.111 |  | Excavation SD16 | 70d | 2014-02-01 | 2014-04-06 | RC.Z2.111 SS | -0.5d | 0d | SSH-Construction Manhours [2200 h] | Z2 |
| SD.BC03.121 |  | Construction of BC03 | 25d | 2014-02-01 | 2014-02-23 | SD.16.111 SS | -0.5d | 0d | SSH-Construction Manhours [2400 h] | Z2 |
| SD.16.121 |  | Shuttering / rebar / wire mesh SD16 | 70d | 2014-02-05 | 2014-04-12 | SD.16.111 SS+6d | 79.5d | 0d | SSH-Construction Manhours [2200 h] | Z2 |
| SD.16.131 |  | Concrete casting SD016 | 70d | 2014-02-11 | 2014-04-17 | SD.16.121 SS+6d | 79.5d | 0d | SSH-Construction Manhours [2200 h] | Z2 |
| SD.04.111 |  | Excavation SD04 | 60d | 2014-02-15 | 2014-04-10 | SD.01.100 SS+15d | -0.5d | 0d | SSH-Construction Manhours [1200 h] | Z3 |
| SD.DP01.111 |  | Construction of DP01 (Drainage Pond 01) | 12d | 2014-02-17 | 2014-02-27 | LS11.110 SS+18d | -0.5d | 0d | SSH-Construction Manhours [1000 h] | Z3 |
| SD.04.121 |  | Shuttering / rebar / wire mesh SD04 | 60d | 2014-02-24 | 2014-04-20 | SD.04.111 SS+10d | -0.5d | 0d | SSH-Construction Manhours [1000 h] | Z3 |
| SD.BC03.131 |  | Backfilling of BC03 | 30d | 2014-02-24 | 2014-03-23 | SD.BC03.121 | -0.5d | 0d | SSH-Construction Manhours [1200 h] | Z2 |
| SD.BC05.111 |  | Excavation for BC05 | 15d | 2014-02-24 | 2014-03-09 | SD.BC03.121 | 0.5d | 0d | SSH-Construction Manhours [600 h] | Z2 |
| SD.17.111 |  | Excavation SD17 | 60d | 2014-02-25 | 2014-04-22 | SD.16.131 SS+15d | 79.5d | 0d | SSH-Construction Manhours [2000 h] | Z2 |
| SD.DP01.121 |  | Construction of RF Spilways DP01 | 20d | 2014-03-01 | 2014-03-18 | SD.DP01.111 | -0.5d | 0d | SSH-Construction Manhours [1000 h] | Z3 |
| SD.17.121 |  | Shuttering / rebar / wire mesh SD17 | 75d | 2014-03-03 | 2014-05-12 | SD.17.111 SS+6d | 79.5d | 0d | SSH-Construction Manhours [2000 h] | Z2 |
| SD.04.131 |  | Concrete casting SD04 | 60d | 2014-03-05 | 2014-04-29 | SD.04.121 SS+10d | -0.5d | 0d | SSH-Construction Manhours [1200 h] | Z3 |
| SD.17.131 |  | Concrete casting SD017 | 75d | 2014-03-09 | 2014-05-18 | SD.17.121 SS+6d | 79.5d | 0d | SSH-Construction Manhours [2000 h] | Z2 |
| SD.BC05.121 |  | Construction of BC05 | 45d | 2014-03-10 | 2014-04-20 | SD.BC05.111 | 0.5d | 0d | SSH-Construction Manhours [2400 h] | Z2 |
| SD.BC08.111 |  | Excavation for BC08 | 15d | 2014-03-10 | 2014-03-24 | SD.BC05.121 SS, SD.BC03.131 SS+16d | -0.5d | 0d | SSH-Construction Manhours [600 h] | Z3 |
| SD.05.111 |  | Excavation SD05 | 50d | 2014-03-15 | 2014-04-29 | SD.04.131 SS+10d | -0.5d | 0d | SSH-Construction Manhours [1200 h] | Z3 |
| SD.DP01.131 |  | Fence installation DP01 | 13d | 2014-03-19 | 2014-03-31 | SD.DP01.121 | -0.5d | 0d | SSH-Construction Manhours [500 h] | Z3 |
| SD.DP02.111 |  | Construction of DP02 | 12d | 2014-03-19 | 2014-03-30 | SD.DP01.131 SS | -0.5d | 0d | SSH-Construction Manhours [1000 h] | Z3 |
| SD.18.111 |  | Excavation SD18 | 75d | 2014-03-23 | 2014-06-01 | SD.17.131 SS+15d | 79.5d | 0d | SSH-Construction Manhours [2000 h] | Z2 |
| SD.05.121 |  | Shuttering / rebar / wire mesh SD05 | 50d | 2014-03-24 | 2014-05-08 | SD.05.111 SS+10d | -0.5d | 0d | SSH-Construction Manhours [1200 h] | Z3 |
| SD.BC08.121 |  | Construction of BC08 | 50d | 2014-03-24 | 2014-05-10 | SD.BC08.111 | -0.5d | 0d | SSH-Construction Manhours [2400 h] | Z3 |
| SD.18.121 |  | Shuttering / rebar / wire mesh SD18 | 75d | 2014-03-29 | 2014-06-05 | SD.18.111 SS+6d | 79.5d | 0d | SSH-Construction Manhours [2000 h] | Z2 |
| SD.DP02.121 |  | Construction of RF Spilways DP02 | 20d | 2014-03-30 | 2014-04-17 | SD.DP02.111 | -0.5d | 0d | SSH-Construction Manhours [1000 h] | Z3 |
| SD.05.131 |  | Concrete casting SD05 | 50d | 2014-04-02 | 2014-05-18 | SD.05.121 SS+10d | -0.5d | 0d | SSH-Construction Manhours [1200 h] | Z3 |
| SD.18.131 |  | Concrete casting SD018 | 75d | 2014-04-02 | 2014-06-11 | SD.18.121 SS+6d | 79.5d | 0d | SSH-Construction Manhours [2000 h] | Z2 |
| SD.22.111 |  | Excavation SD22 | 30d | 2014-04-10 | 2014-05-08 | SW.131 | 128.5d | 0d | SSH-Construction Manhours [800 h] | Z1 |
| SD.06.111 |  | Excavation SD06 | 45d | 2014-04-12 | 2014-05-22 | SD.05.131 SS+10d | -0.5d | 0d | SSH-Construction Manhours [1200 h] | Z3 |
| SD.22.121 |  | Shuttering / rebar / wire mesh SD22 | 30d | 2014-04-16 | 2014-05-13 | SD.22.111 SS+6d | 128.5d | 0d | SSH-Construction Manhours [800 h] | Z1 |
| SD.19.111 |  | Excavation SD19 | 75d | 2014-04-16 | 2014-06-25 | SD.18.131 SS+15d | 79.5d | 0d | SSH-Construction Manhours [1600 h] | Z2 |
| SD.22.131 |  | Concrete casting SD022 | 30d | 2014-04-17 | 2014-05-15 | SD.22.121 SS+2d | 128.5d | 0d | SSH-Construction Manhours [800 h] | Z1 |
| SD.DP02.131 |  | Fence installation DP02 | 13d | 2014-04-17 | 2014-04-29 | SD.DP02.121 | -0.5d | 0d | SSH-Construction Manhours [500 h] | Z3 |
| SD.DP03.111 |  | Construction of DP03 | 12d | 2014-04-17 | 2014-04-29 | SD.DP02.121 | 0.5d | 1d | SSH-Construction Manhours [1000 h] | Z3 |
| SD.06.121 |  | Shuttering / rebar / wire mesh SD06 | 45d | 2014-04-21 | 2014-06-01 | SD.06.111 SS+10d | -0.5d | 0d | SSH-Construction Manhours [1200 h] | Z3 |
| SD.BC01.111 |  | Excavation for BC01 (Box Culvert 01) | 15d | 2014-04-21 | 2014-05-04 | SD.BC05.121 | 55.5d | 0d | SSH-Construction Manhours [600 h] | Z2 |
| SD.BC05.131 |  | Backfilling of BC05 | 30d | 2014-04-21 | 2014-05-18 | SD.BC05.121 | 25.5d | 26d | SSH-Construction Manhours [1200 h] | Z2 |
| SD.BC06.111 |  | Excavation for BC06 | 15d | 2014-04-21 | 2014-05-04 | SD.BC05.121 | 30.5d | 0d | SSH-Construction Manhours [600 h] | Z2 |
| SD.19.121 |  | Shuttering / rebar / wire mesh SD19 | 75d | 2014-04-22 | 2014-07-01 | SD.19.111 SS+6d | 79.5d | 0d | SSH-Construction Manhours [1600 h] | Z2 |
| SD.19.131 |  | Concrete casting SD019 | 75d | 2014-04-28 | 2014-07-07 | SD.19.121 SS+6d | 79.5d | 0d | SSH-Construction Manhours [1600 h] | Z2 |
| SD.06.131 |  | Concrete casting SD06 | 45d | 2014-04-29 | 2014-06-10 | SD.06.121 SS+9d | -0.5d | 0d | SSH-Construction Manhours [1200 h] | Z3 |
| SD.DP03.121 |  | Construction of RF Spilways DP03 | 20d | 2014-04-30 | 2014-05-18 | SD.DP02.131, SD.DP03.111 | -0.5d | 0d | SSH-Construction Manhours [1000 h] | Z3 |
| SD.BC01.121 |  | Construction of BC01 | 51d | 2014-05-05 | 2014-06-21 | SD.BC01.111 | 55.5d | 0d | SSH-Construction Manhours [2400 h] | Z2 |
| SD.BC06.121 |  | Construction of BC06 | 45d | 2014-05-05 | 2014-06-15 | SD.BC06.111 | 30.5d | 0d | SSH-Construction Manhours [2400 h] | Z2 |
| SD.07.111 |  | Excavation SD07 | 90d | 2014-05-08 | 2014-07-31 | SD.06.131 SS+10d | -0.5d | 0d | SSH-Construction Manhours [2600 h] | Z3 |
| SD.BC08.131 |  | Backfilling of BC08 | 25d | 2014-05-10 | 2014-06-02 | SD.BC08.121 | 21.5d | 22d | SSH-Construction Manhours [1200 h] | Z3 |
| SD.BC09.111 |  | Excavation for BC09 | 15d | 2014-05-10 | 2014-05-24 | SD.BC08.121 | -0.5d | 0d | SSH-Construction Manhours [600 h] | Z3 |
| SD.20.111 |  | Excavation SD20 | 60d | 2014-05-12 | 2014-07-07 | SD.19.131 SS+15d | 79.5d | 0d | SSH-Construction Manhours [1500 h] | Z2 |
| SD.07.121 |  | Shuttering / rebar / wire mesh SD07 | 90d | 2014-05-18 | 2014-08-10 | SD.07.111 SS+10d | -0.5d | 0d | SSH-Construction Manhours [4000 h] | Z3 |
| SD.20.121 |  | Shuttering / rebar / wire mesh SD20 | 60d | 2014-05-18 | 2014-07-13 | SD.20.111 SS+6d | 79.5d | 0d | SSH-Construction Manhours [1500 h] | Z2 |
| SD.DP03.131 |  | Fence installation DP03 | 13d | 2014-05-19 | 2014-05-31 | SD.DP03.121 | -0.5d | 0d | SSH-Construction Manhours [500 h] | Z3 |
| SD.DP04.111 |  | Construction of DP04 | 12d | 2014-05-19 | 2014-05-29 | SD.DP03.121 | 0.5d | 1d | SSH-Construction Manhours [1000 h] | Z3 |
| SD.01.111 |  | Excavation SD01 (Storm Ditch) | 75d | 2014-05-24 | 2014-07-31 | SD.06.111 | 85.5d | 0d | SSH-Construction Manhours [1800 h] | Z4 |
| SD.20.131 |  | Concrete casting SD020 | 60d | 2014-05-24 | 2014-07-17 | SD.20.121 SS+6d | 79.5d | 0d | SSH-Construction Manhours [1500 h] | Z2 |
| SD.BC09.121 |  | Construction of BC09 | 50d | 2014-05-24 | 2014-07-09 | SD.BC09.111, SD.BC05.131 SS+10d | -0.5d | 0d | SSH-Construction Manhours [2400 h] | Z3 |
| SD.07.131 |  | Concrete casting SD07 | 90d | 2014-05-25 | 2014-08-17 | SD.07.121 SS+8d | -0.5d | 0d | SSH-Construction Manhours [4000 h] | Z3 |
| SD.01.121 |  | Shuttering / rebar / wire mesh SD01 | 75d | 2014-05-28 | 2014-08-06 | SD.01.111 SS+6d | 85.5d | 0d | SSH-Construction Manhours [3600 h] | Z4 |
| SD.08.111 |  | Excavation SD08 | 90d | 2014-05-31 | 2014-08-23 | SD.07.131 SS+6d | -0.5d | 0d | SSH-Construction Manhours [2600 h] | Z3 |
| SD.DP04.121 |  | Construction of RF Spilways DP04 | 20d | 2014-05-31 | 2014-06-18 | SD.DP04.111, SD.DP03.131, SD.BC08.131 SS | -0.5d | 0d | SSH-Construction Manhours [1000 h] | Z3 |
| SD.01.131 |  | Concrete casting SD01 | 75d | 2014-06-03 | 2014-08-12 | SD.01.121 SS+6d | 85.5d | 0d | SSH-Construction Manhours [3600 h] | Z4 |
| SD.08.121 |  | Shuttering / rebar / wire mesh SD08 | 90d | 2014-06-05 | 2014-08-28 | SD.08.111 SS+6d | -0.5d | 0d | SSH-Construction Manhours [4000 h] | Z3 |
| SD.21.111 |  | Excavation SD21 | 45d | 2014-06-07 | 2014-07-17 | SD.20.131 SS+15d | 79.5d | 0d | SSH-Construction Manhours [1400 h] | Z2 |
| SD.02.111 |  | Excavation SD02 | 90d | 2014-06-09 | 2014-09-01 | SD.01.131 SS+6d | 85.5d | 0d | SSH-Construction Manhours [1800 h] | Z4 |
| SD.08.131 |  | Concrete casting SD08 | 90d | 2014-06-11 | 2014-09-02 | SD.08.121 SS+6d | -0.5d | 0d | SSH-Construction Manhours [4000 h] | Z3 |
| SD.21.121 |  | Shuttering / rebar / wire mesh SD21 | 45d | 2014-06-11 | 2014-07-23 | SD.21.111 SS+6d | 79.5d | 0d | SSH-Construction Manhours [1400 h] | Z2 |
| SD.02.121 |  | Shuttering / rebar / wire mesh SD02 | 90d | 2014-06-15 | 2014-09-07 | SD.02.111 SS+6d | 85.5d | 0d | SSH-Construction Manhours [4300 h] | Z4 |
| SD.09.111 |  | Excavation SD09 | 110d | 2014-06-16 | 2014-09-25 | SD.08.131 SS+5d | -0.5d | 0d | SSH-Construction Manhours [2600 h] | Z3 |
| SD.BC06.131 |  | Backfilling of BC06 | 30d | 2014-06-16 | 2014-07-13 | SD.BC06.121, SD.BC05.131 | 30.5d | 30d | SSH-Construction Manhours [1200 h] | Z2 |
| SD.BC07.111 |  | Excavation for BC07 | 15d | 2014-06-16 | 2014-06-29 | SD.BC06.121 | 30.5d | 0d | SSH-Construction Manhours [600 h] | Z2 |

| ID | Activity | Type | Duration | Start | Finish | Predecessors | Total float | Free float | Resources | Department |
| --- | --- | --- | --- | --- | --- | --- | --- | --- | --- | --- |
| SD.21.131 | Concrete casting SD021 |  | 45d | 2014-06-17 | 2014-07-29 | SD.21.121 SS+6d | 79.5d | 24d | SSH-Construction Manhours [1400 h] | Z2 |
| SD.DP04.131 | Fence installation DP04 |  | 13d | 2014-06-18 | 2014-06-30 | SD.DP04.121 | -0.5d | 0d | SSH-Construction Manhours [500 h] | Z3 |
| SD.DP05.111 | Construction of DP05 |  | 12d | 2014-06-18 | 2014-06-29 | SD.DP04.121 | 0.5d | 1d | SSH-Construction Manhours [1000 h] | Z3 |
| SD.02.131 | Concrete casting SD02 |  | 90d | 2014-06-21 | 2014-09-11 | SD.02.121 SS+6d | 85.5d | 86d | SSH-Construction Manhours [4300 h] | Z4 |
| SD.09.121 | Shuttering / rebar / wire mesh SD09 |  | 110d | 2014-06-21 | 2014-10-01 | SD.09.111 SS+6d | -0.5d | 0d | SSH-Construction Manhours [4800 h] | Z3 |
| SD.BC01.131 | Backfilling of BC01 |  | 30d | 2014-06-21 | 2014-07-19 | SD.BC01.121 | 144.5d | 145d | SSH-Construction Manhours [1200 h] | Z2 |
| SD.BC02.111 | Excavation for BC02 |  | 15d | 2014-06-21 | 2014-07-05 | SD.BC01.121 | 55.5d | 0d | SSH-Construction Manhours [600 h] | Z2 |
| SD.09.131 | Concrete casting SD09 |  | 110d | 2014-06-26 | 2014-10-07 | SD.09.121 SS+6d | -0.5d | 0d | SSH-Construction Manhours [4800 h] | Z3 |
| SD.BC07.121 | Construction of BC07 |  | 45d | 2014-06-30 | 2014-08-10 | SD.BC07.111 | 30.5d | 0d | SSH-Construction Manhours [2400 h] | Z2 |
| SD.DP05.121 | Construction of RF Spilways DP05 |  | 20d | 2014-06-30 | 2014-07-19 | SD.DP04.131, SD.DP05.111 | -0.5d | 0d | SSH-Construction Manhours [1000 h] | Z3 |
| SD.10.111 | Excavation SD10 |  | 100d | 2014-07-01 | 2014-10-02 | SD.09.131 SS+5d | -0.5d | 0d | SSH-Construction Manhours [2000 h] | Z3 |
| SD.BC02.121 | Construction of BC02 |  | 50d | 2014-07-05 | 2014-08-20 | SD.BC02.111 | 55.5d | 0d | SSH-Construction Manhours [2400 h] | Z2 |
| SD.10.121 | Shuttering / rebar / wire mesh SD10 |  | 100d | 2014-07-07 | 2014-10-08 | SD.10.111 SS+6d | -0.5d | 0d | SSH-Construction Manhours [4000 h] | Z3 |
| SD.BC09.131 | Backfilling of BC09 |  | 25d | 2014-07-09 | 2014-08-02 | SD.BC09.121, SD.BC08.131 | 22.5d | 23d | SSH-Construction Manhours [1200 h] | Z3 |
| SD.BC10.111 | Excavation for BC10 |  | 15d | 2014-07-09 | 2014-07-23 | SD.BC09.121 | -0.5d | 0d | SSH-Construction Manhours [600 h] | Z3 |
| SD.10.131 | Concrete casting SD010 |  | 100d | 2014-07-13 | 2014-10-14 | SD.10.121 SS+6d | -0.5d | 0d | SSH-Construction Manhours [4000 h] | Z3 |
| SD.11.111 | Excavation SD11 |  | 100d | 2014-07-17 | 2014-10-19 | SD.10.131 SS+5d | -0.5d | 0d | SSH-Construction Manhours [2000 h] | Z3 |
| SD.DP05.131 | Fence installation DP05 |  | 13d | 2014-07-19 | 2014-07-31 | SD.DP05.121 | -0.5d | 0d | SSH-Construction Manhours [500 h] | Z3 |
| SD.DP06.111 | Construction of DP06 |  | 12d | 2014-07-19 | 2014-07-30 | SD.DP05.121 | 0.5d | 1d | SSH-Construction Manhours [1000 h] | Z3 |
| SD.11.121 | Shuttering / rebar / wire mesh SD11 |  | 100d | 2014-07-23 | 2014-10-23 | SD.11.111 SS+6d | -0.5d | 0d | SSH-Construction Manhours [4000 h] | Z3 |
| SD.BC10.121 | Construction of BC10 |  | 50d | 2014-07-23 | 2014-09-08 | SD.BC06.131 SS+10d, SD.BC10.111 | -0.5d | 0d | SSH-Construction Manhours [2400 h] | Z3 |
| SD.11.131 | Concrete casting SD011 |  | 100d | 2014-07-28 | 2014-10-29 | SD.11.121 SS+6d | -0.5d | 0d | SSH-Construction Manhours [4000 h] | Z3 |
| SD.DP06.121 | Construction of RF Spilways DP06 |  | 20d | 2014-07-31 | 2014-08-19 | SD.BC09.131 SS, SD.DP05.131, SD.DP06.111 | -0.5d | 0d | SSH-Construction Manhours [1000 h] | Z3 |
| SD.12.111 | Excavation SD12 |  | 100d | 2014-08-02 | 2014-11-03 | SD.11.131 SS+5d | -0.5d | 0d | SSH-Construction Manhours [2000 h] | Z3 |
| SD.12.121 | Shuttering / rebar / wire mesh SD12 |  | 100d | 2014-08-07 | 2014-11-09 | SD.12.111 SS+6d | -0.5d | 0d | SSH-Construction Manhours [4000 h] | Z3 |
| SD.BC07.131 | Backfilling of BC07 |  | 28d | 2014-08-11 | 2014-09-06 | SD.BC06.131, SD.BC07.121 | 30.5d | 31d | SSH-Construction Manhours [1200 h] | Z2 |
| SD.12.131 | Concrete casting SD012 |  | 100d | 2014-08-13 | 2014-11-15 | SD.12.121 SS+6d | -0.5d | 0d | SSH-Construction Manhours [4000 h] | Z3 |
| SD.13.111 | Excavation SD13 |  | 90d | 2014-08-18 | 2014-11-10 | SD.12.131 SS+5d | -0.5d | 0d | SSH-Construction Manhours [2000 h] | Z3 |
| SD.DP06.131 | Fence installation DP06 |  | 13d | 2014-08-19 | 2014-08-31 | SD.DP06.121 | -0.5d | 0d | SSH-Construction Manhours [500 h] | Z3 |
| SD.DP07.111 | Construction of DP07 |  | 12d | 2014-08-19 | 2014-08-30 | SD.DP06.121 | 0.5d | 1d | SSH-Construction Manhours [1000 h] | Z3 |
| SD.BC02.131 | Backfilling of BC02 |  | 30d | 2014-08-20 | 2014-09-17 | SD.BC02.121, SD.21.131 | 55.5d | 0d | SSH-Construction Manhours [1200 h] | Z2 |
| SD.DP10.111 | Construction of DP10 |  | 15d | 2014-08-20 | 2014-09-03 | SD.BC02.131 SS, SD.BC07.121 | 55.5d | 0d | SSH-Construction Manhours [1000 h] | Z2 |
| SD.13.121 | Shuttering / rebar / wire mesh SD13 |  | 90d | 2014-08-24 | 2014-11-16 | SD.13.111 SS+6d | -0.5d | 0d | SSH-Construction Manhours [4000 h] | Z3 |
| SD.13.131 | Concrete casting SD013 |  | 90d | 2014-08-30 | 2014-11-20 | SD.13.121 SS+6d | -0.5d | 0d | SSH-Construction Manhours [4000 h] | Z3 |
| SD.DP07.121 | Construction of RF Spilways DP07 |  | 20d | 2014-08-31 | 2014-09-18 | SD.DP07.111, SD.DP06.131 | -0.5d | 0d | SSH-Construction Manhours [1000 h] | Z3 |
| SD.14.111 | Excavation SD14 |  | 75d | 2014-09-03 | 2014-11-11 | SD.13.131 SS+5d | -0.5d | 0d | SSH-Construction Manhours [1800 h] | Z3 |
| SD.DP10.121 | Construction of RF Spilways DP10 |  | 15d | 2014-09-03 | 2014-09-17 | SD.DP10.111 | 55.5d | 0d | SSH-Construction Manhours [1000 h] | Z2 |
| SD.14.121 | Shuttering / rebar / wire mesh SD14 |  | 75d | 2014-09-08 | 2014-11-17 | SD.14.111 SS+6d | -0.5d | 0d | SSH-Construction Manhours [3000 h] | Z3 |
| SD.BC10.131 | Backfilling of BC10 |  | 25d | 2014-09-08 | 2014-10-01 | SD.BC10.121, SD.BC09.131 | 18.5d | 19d | SSH-Construction Manhours [1200 h] | Z3 |
| SD.BC11.111 | Excavation for BC11 |  | 15d | 2014-09-08 | 2014-09-22 | SD.BC10.121 | -0.5d | 0d | SSH-Construction Manhours [600 h] | Z3 |
| SD.14.131 | Concrete casting SD014 |  | 75d | 2014-09-14 | 2014-11-23 | SD.14.121 SS+6d | -0.5d | 0d | SSH-Construction Manhours [3000 h] | Z3 |
| SD.15.111 | Excavation SD15 |  | 70d | 2014-09-17 | 2014-11-22 | SD.14.131 SS+4d | -0.5d | 0d | SSH-Construction Manhours [1800 h] | Z3 |
| SD.DP10.131 | Fence installation DP10 |  | 14d | 2014-09-17 | 2014-09-30 | SD.DP10.121 | 55.5d | 0d | SSH-Construction Manhours [500 h] | Z2 |
| SD.DP07.131 | Fence installation DP07 |  | 13d | 2014-09-18 | 2014-09-30 | SD.DP07.121 | -0.5d | 0d | SSH-Construction Manhours [500 h] | Z3 |
| SD.DP08.111 | Construction of DP08 |  | 12d | 2014-09-18 | 2014-09-30 | SD.DP07.121 | 0.5d | 1d | SSH-Construction Manhours [1000 h] | Z3 |
| SD.15.121 | Shuttering / rebar / wire mesh SD15 |  | 70d | 2014-09-22 | 2014-11-26 | SD.15.111 SS+5d | -0.5d | 0d | SSH-Construction Manhours [3200 h] | Z3 |
| SD.BC11.121 | Construction of BC11 |  | 50d | 2014-09-22 | 2014-11-08 | SD.BC11.111, SD.BC07.131 SS+15d | -0.5d | 0d | SSH-Construction Manhours [2400 h] | Z3 |
| SD.15.131 | Concrete casting SD015 |  | 70d | 2014-09-27 | 2014-12-01 | SD.15.121 SS+5d | -0.5d | 0d | SSH-Construction Manhours [3200 h] | Z3 |
| SD.DP08.121 | Construction of RF Spilways DP08 |  | 20d | 2014-10-01 | 2014-10-19 | SD.DP07.131, SD.DP08.111 | -0.5d | 0d | SSH-Construction Manhours [1000 h] | Z3 |
| SD.DP08.131 | Fence installation DP08 |  | 13d | 2014-10-20 | 2014-11-01 | SD.DP07.131, SD.BC10.131, SD.DP08.121 | -0.5d | 0d | SSH-Construction Manhours [500 h] | Z3 |
| SD.DP09.111 | Construction of DP09 |  | 12d | 2014-10-20 | 2014-10-30 | SD.DP08.121 | 0.5d | 1d | SSH-Construction Manhours [1000 h] | Z3 |
| SD.DP09.121 | Construction of RF Spilways DP09 |  | 20d | 2014-11-01 | 2014-11-19 | SD.DP08.131, SD.DP09.111 | -0.5d | 0d | SSH-Construction Manhours [1000 h] | Z3 |
| SD.BC11.131 | Backfilling of BC11 |  | 25d | 2014-11-08 | 2014-12-01 | SD.BC11.121, SD.BC10.131 SS | -0.5d | 0d | SSH-Construction Manhours [1200 h] | Z3 |
| SD.DP09.131 | Fence installation DP09 |  | 13d | 2014-11-19 | 2014-12-01 | SD.DP09.121 | -0.5d | 0d | SSH-Construction Manhours [500 h] | Z3 |
| SD.Works.999 | Strom Ditch Network Finish | milestone | 0d | 2014-12-01 | 2014-12-01 | SD.DP08.131, SD.22.131, SD.BC03.131, SD.BC08.131, SD.DP04.131, SD.02.131, SD.DP05.131, SD.15.131, SD.DP07.131, SD.BC02.131, SD.BC05.131, SD.BC10.131, SD.DP03.131, SD.BC11.131, SD.BC06.131, SD.DP01.131, SD.DP09.131, SD.BC09.131, SD.DP02.131, SD.DP06.131, SD.DP10.131, SD.BC01.131, SD.BC07.131 | -0.5d | 0d |  | Z3 |

| ID | WBS | Activity | Type | Duration | Start | Finish | Predecessors | Total float | Free float | Resources | Department |
| --- | --- | --- | --- | --- | --- | --- | --- | --- | --- | --- | --- |
|  | 13 | **Permanent Road Works** |  |  | 2014-04-16 | 2014-11-02 |  |  |  |  |  |
| RD.111 |  | Sub-Base laying Road D |  | 30d | 2014-04-16 | 2014-05-14 | RC.Z2.113 | 61.5d | 0d | SSH-Construction Manhours [1200 h] | Z2 |
| RD.121 |  | Base laying Road D |  | 30d | 2014-04-26 | 2014-05-24 | RD.111 SS+10d | 139.5d | 0d | SSH-Construction Manhours [600 h] | Z2 |
| RA.111 |  | Sub-Base laying Road A |  | 50d | 2014-04-30 | 2014-06-15 | SD.04.131 | 30.5d | 0d | SSH-Construction Manhours [3600 h] | Z3 |
| RD.131 |  | Curbs & gutters casting Road D |  | 20d | 2014-05-05 | 2014-05-24 | RD.121 SS+10d | 139.5d | 0d | SSH-Construction Manhours [800 h] | Z2 |
| RA.121 |  | Base laying Road A |  | 60d | 2014-05-10 | 2014-07-03 | RA.111 SS+10d | 30.5d | 0d | SSH-Construction Manhours [3600 h] | Z3 |
| RC.111 |  | Sub-Base laying Road C |  | 50d | 2014-05-14 | 2014-06-30 | RD.111 | 61.5d | 0d | SSH-Construction Manhours [2400 h] | Z2 |
| RD.141 |  | Trees Installation Road d |  | 20d | 2014-05-14 | 2014-06-02 | RD.131 SS+10d | 139.5d | 0d | SSH-Construction Manhours [1000 h] | Z2 |
| RD.151 |  | Prime Coat laying Road d |  | 20d | 2014-05-14 | 2014-06-02 | RD.141 SS | 139.5d | 0d | SSH-Construction Manhours [600 h] | Z2 |
| RC.121 |  | Base laying Road C |  | 60d | 2014-05-20 | 2014-07-15 | RC.111 SS+6d | 61.5d | 0d | SSH-Construction Manhours [2400 h] | Z2 |
| RD.161 |  | Binder Coarse Road D |  | 20d | 2014-05-24 | 2014-06-11 | RD.151 SS+10d | 139.5d | 0d | SSH-Construction Manhours [1000 h] | Z2 |
| RA.131 |  | Curbs & gutters casting Road A |  | 60d | 2014-05-28 | 2014-07-22 | RA.121 SS+20d | 30.5d | 0d | SSH-Construction Manhours [2000 h] | Z3 |
| RC.131 |  | Curbs & gutters casting Road C |  | 45d | 2014-05-29 | 2014-07-10 | RC.121 SS+10d | 61.5d | 0d | SSH-Construction Manhours [1600 h] | Z2 |
| RD.171 |  | Tack Coat Road D |  | 20d | 2014-06-02 | 2014-06-21 | RD.161 SS+10d | 139.5d | 0d | SSH-Construction Manhours [600 h] | Z2 |
| RC.141 |  | Trees Installation Road C |  | 60d | 2014-06-08 | 2014-08-03 | RC.131 SS+10d | 61.5d | 0d | SSH-Construction Manhours [2000 h] | Z2 |
| RD.181 |  | Wearing coarse Road D |  | 20d | 2014-06-11 | 2014-06-30 | RD.171 SS+10d | 139.5d | 0d | SSH-Construction Manhours [2000 h] | Z2 |
| RC.151 |  | Prime Coat laying Road C |  | 45d | 2014-06-14 | 2014-07-26 | RC.141 SS+6d | 61.5d | 0d | SSH-Construction Manhours [1200 h] | Z2 |
| RB.111 |  | Sub-Base laying Road B |  | 30d | 2014-06-16 | 2014-07-13 | RA.111 | 75.5d | 0d | SSH-Construction Manhours [1000 h] | Z3 |
| RA.141 |  | Trees Installation Road A |  | 90d | 2014-06-21 | 2014-09-11 | RA.131 SS+25d | 30.5d | 0d | SSH-Construction Manhours [1000 h] | Z3 |
| RA.151 |  | Prime Coat laying Road A |  | 60d | 2014-06-21 | 2014-08-14 | RA.141 SS | 30.5d | 0d | SSH-Construction Manhours [1000 h] | Z3 |
| RC.161 |  | Binder Coarse Road C |  | 45d | 2014-06-25 | 2014-08-06 | RC.151 SS+13d | 61.5d | 0d | SSH-Construction Manhours [2000 h] | Z2 |
| RB.121 |  | Base laying Road B |  | 30d | 2014-06-30 | 2014-07-27 | RB.111 SS+15d | 75.5d | 0d | SSH-Construction Manhours [1000 h] | Z3 |
| RD.191 |  | Road Marking, Signs Road D |  | 15d | 2014-06-30 | 2014-07-14 | RD.181 | 139.5d | 84d | SSH-Construction Manhours [400 h] | Z2 |
| RA.161 |  | Binder Coarse Road A |  | 60d | 2014-07-05 | 2014-08-28 | RA.151 SS+15d | 30.5d | 0d | SSH-Construction Manhours [2000 h] | Z3 |
| RC.171 |  | Tack Coat Road C |  | 45d | 2014-07-08 | 2014-08-19 | RC.161 SS+13d | 61.5d | 0d | SSH-Construction Manhours [1200 h] | Z2 |
| RB.131 |  | Curbs & gutters casting Road B |  | 20d | 2014-07-14 | 2014-07-31 | RB.121 SS+15d | 75.5d | 0d | SSH-Construction Manhours [800 h] | Z3 |
| RC.181 |  | Wearing coarse Road C |  | 42d | 2014-07-20 | 2014-08-28 | RC.171 SS+13d | 61.5d | 0d | SSH-Construction Manhours [4000 h] | Z2 |
| RB.141 |  | Trees Installation Road B |  | 20d | 2014-07-23 | 2014-08-10 | RB.131 SS+10d | 75.5d | 0d | SSH-Construction Manhours [600 h] | Z3 |
| RB.151 |  | Prime Coat laying Road B |  | 20d | 2014-07-23 | 2014-08-10 | RB.141 SS | 75.5d | 0d | SSH-Construction Manhours [600 h] | Z3 |
| RA.171 |  | Tack Coat Road A |  | 60d | 2014-07-28 | 2014-09-21 | RA.161 SS+25d | 30.5d | 0d | SSH-Construction Manhours [1000 h] | Z3 |
| RB.161 |  | Binder Coarse Road B |  | 20d | 2014-08-02 | 2014-08-19 | RB.151 SS+10d | 75.5d | 0d | SSH-Construction Manhours [1000 h] | Z3 |
| RA.181 |  | Wearing coarse Road A |  | 60d | 2014-08-11 | 2014-10-05 | RA.171 SS+15d | 30.5d | 0d | SSH-Construction Manhours [4000 h] | Z3 |
| RB.171 |  | Tack Coat Road B |  | 20d | 2014-08-11 | 2014-08-28 | RB.161 SS+10d | 75.5d | 0d | SSH-Construction Manhours [600 h] | Z3 |
| RB.181 |  | Wearing coarse Road B |  | 20d | 2014-08-20 | 2014-09-07 | RB.171 SS+10d | 75.5d | 0d | SSH-Construction Manhours [1000 h] | Z3 |
| RC.191 |  | Road Marking, Signs Road C |  | 30d | 2014-08-28 | 2014-09-25 | RC.181 | 61.5d | 6d | SSH-Construction Manhours [800 h] | Z2 |
| RB.191 |  | Road Marking, Signs Road B |  | 15d | 2014-09-08 | 2014-09-21 | RB.181 | 75.5d | 45d | SSH-Construction Manhours [400 h] | Z3 |
| RA.191 |  | Road Marking, Signs Road A |  | 30d | 2014-10-06 | 2014-11-02 | RA.181 | 30.5d | 0d | SSH-Construction Manhours [600 h] | Z3 |
| RD.999 |  | Road Works Finish | milestone | 0d | 2014-11-02 | 2014-11-02 | RD.191, RC.191, RB.191, RA.191 | 30.5d | 0d |  | Z3 |

| ID | WBS | Activity | Type | Duration | Start | Finish | Predecessors | Total float | Free float | Resources | Department |
| --- | --- | --- | --- | --- | --- | --- | --- | --- | --- | --- | --- |
|  | 14 | **Public Realm** |  |  | 2014-02-15 | 2014-11-20 |  |  |  |  |  |
| PR.S3.311 |  | Balance Walkways construction segment 3 |  | 55d | 2014-02-15 | 2014-04-06 | PR.S4.111 SS | 30.5d | 0d | SSH-Construction Manhours [800 h] | Z3 |
| PR.S4.121 |  | Balance Landscaping works Segment 4 |  | 90d | 2014-02-15 | 2014-05-08 | PR.S4.111 SS | 10.5d | 0d | SSH-Construction Manhours [800 h] | Z3 |
| PR.S4.141 |  | Balance Solar lighting system installation Segment 4 |  | 60d | 2014-03-01 | 2014-04-24 | PR.S4.131 SS+15d | 25.5d | 15d | SSH-Construction Manhours [400 h] | Z3 |
| PR.S3.321 |  | Balance Cartway construction segment 3 |  | 60d | 2014-03-24 | 2014-05-18 | PR.S3.311 SS+40d | 30.5d | 0d | SSH-Construction Manhours [1000 h] | Z3 |
| PR.S2.511 |  | Balance Walkways construction segment 2 |  | 45d | 2014-04-07 | 2014-05-18 | PR.S3.311 | 45.5d | 0d | SSH-Construction Manhours [1500 h] | Z3 |
| PR.S2.521 |  | Balance Cartway construction segment 2 |  | 45d | 2014-04-21 | 2014-06-01 | PR.S2.511 SS+15d | 45.5d | 0d | SSH-Construction Manhours [1500 h] | Z3 |
| PR.S2.531 |  | Balance Curbs & gutters construction segment 2 |  | 45d | 2014-05-05 | 2014-06-15 | PR.S2.521 SS+15d | 45.5d | 0d | SSH-Construction Manhours [1500 h] | Z3 |
| PR.S3.331 |  | Balance Curbs & gutters construction segment 3 |  | 60d | 2014-05-05 | 2014-06-29 | PR.S3.321 SS+45d | 30.5d | 20d | SSH-Construction Manhours [1000 h] | Z3 |
| PR.S3.361 |  | Balance Landscaping works Segment 3 |  | 60d | 2014-05-10 | 2014-07-03 | PR.S3.351 | 10.5d | 0d | SSH-Construction Manhours [500 h] | Z3 |
| PR.S3.381 |  | Balance Solar lighting system installation Segment 3 |  | 30d | 2014-05-10 | 2014-06-05 | PR.S4.141, PR.S3.371 SS+30d | 10.5d | 0d | SSH-Construction Manhours [1000 h] | Z3 |
| PR.S1.711 |  | Balance Walkways construction segment 1 |  | 60d | 2014-05-19 | 2014-07-13 | PR.S2.511 | 45.5d | 0d | SSH-Construction Manhours [2000 h] | Z3 |
| PR.S2.541 |  | Balance LV cables installation segment 2 |  | 30d | 2014-05-19 | 2014-06-15 | PR.S2.531 SS+15d | 110.5d | 0d | SSH-Construction Manhours [1000 h] | Z3 |
| PR.S2.561 |  | Balance Landscaping works Segment 2 |  | 60d | 2014-05-19 | 2014-07-13 | PR.S2.551 SS+10d | 15.5d | 0d | SSH-Construction Manhours [1500 h] | Z3 |
| PR.S1.721 |  | Balance Cartway construction segment 1 |  | 60d | 2014-06-02 | 2014-07-27 | PR.S1.711 SS+15d | 80.5d | 0d | SSH-Construction Manhours [1000 h] | Z3 |
| PR.S3.341 |  | Balance LV cables installation segment 3 |  | 30d | 2014-06-07 | 2014-07-03 | PR.S3.331 SS+15d, PR.S3.381 | 10.5d | 0d | SSH-Construction Manhours [1000 h] | Z3 |
| PR.S1.731 |  | Balance Curbs & gutters construction segment 1 |  | 60d | 2014-06-16 | 2014-08-10 | PR.S1.721 SS+15d | 80.5d | 0d | SSH-Construction Manhours [1000 h] | Z3 |
| PR.S2.591 |  | Balance Fountain construction Segment 2 |  | 60d | 2014-06-16 | 2014-08-10 | PR.S2.541 | 110.5d | 109d | SSH-Construction Manhours [1000 h] | Z3 |
| PR.S3.391 |  | Balance Fountain construction Segment 3 |  | 60d | 2014-07-05 | 2014-08-28 | PR.S3.341, PR.S3.381, PR.S3.361 | 10.5d | 0d | SSH-Construction Manhours [1000 h] | Z3 |
| PR.S1.741 |  | Balance LV cables installation segment 1 |  | 30d | 2014-07-14 | 2014-08-10 | PR.S1.731 SS+30d | 80.5d | 0d | SSH-Construction Manhours [1000 h] | Z3 |
| PR.S2.581 |  | Balance Solar lighting system installation Segment 2 |  | 30d | 2014-07-14 | 2014-08-10 | PR.S3.341, PR.S2.531, PR.S2.571 SS+30d, PR.S3.361, PR.S2.561 | 15.5d | 0d | SSH-Construction Manhours [1000 h] | Z3 |
| PR.S1.751 |  | Balance Solar lighting system installation Segment 1 |  | 30d | 2014-08-11 | 2014-09-07 | PR.S1.741 | 80.5d | 79d | SSH-Construction Manhours [1000 h] | Z3 |
| PR.S5.811 |  | LV Cable Isntallation segment 5 |  | 30d | 2014-08-11 | 2014-09-07 | PR.S1.711, PR.S3.331, PR.S2.581 | 15.5d | 5d | SSH-Construction Manhours [500 h] | Z3 |
| PR.S5.841 |  | Walways construction segment 5 |  | 60d | 2014-08-30 | 2014-10-23 | PR.S3.391, PR.S5.811 SS+15d | 10.5d | 0d | SSH-Construction Manhours [1000 h] | Z3 |
| PR.S5.871 |  | Fountain construction Segment 5 |  | 60d | 2014-09-17 | 2014-11-11 | PR.S5.841 SS+20d | 10.5d | 9d | SSH-Construction Manhours [2000 h] | Z3 |
| PR.S5.851 |  | Landscaping works Segment 5 |  | 40d | 2014-10-14 | 2014-11-20 | T1.999, PR.S5.841 SS | 1.5d | 0d | SSH-Construction Manhours [2000 h] | Z3 |
| PR.S5.861 |  | Solar lighting system installation Segment 5 |  | 30d | 2014-10-23 | 2014-11-20 | PR.S5.851 SS+10d | 1.5d | 0d | SSH-Construction Manhours [1000 h] | Z3 |
| PR.Works.999 |  | Public Realm Works Finish | milestone | 0d | 2014-11-20 | 2014-11-20 | PR.S1.751, PR.S5.861, PR.S3.381, PR.S5.871, PR.S3.391, PR.S5.851, PR.S2.581, PR.S4.141, PR.S2.591 | 1.5d | 0d |  | Z3 |

| ID | WBS | Activity | Type | Duration | Start | Finish | Predecessors | Total float | Free float | Resources | Department |
| --- | --- | --- | --- | --- | --- | --- | --- | --- | --- | --- | --- |
|  | 15 | **Power Distribution** |  |  | 2014-02-01 | 2014-06-19 |  |  |  |  |  |
| E.LP.RA.111 |  | Balance LV Cable Installation - Road A |  | 45d | 2014-02-01 | 2014-03-13 | Eng.110 SS | 5.5d | 0d | SSH-Construction Manhours [2800 h] | Z3 |
| E.RMU.Z3.111 |  | RMU installation - Z3 |  | 30d | 2014-02-01 | 2014-02-27 | E.LP.RA.111 SS | 5.5d | 0d | SSH-Construction Manhours [1500 h] | Z3 |
| E.LP.RA.121 |  | Lighting pole/fixtures Installation - Road A |  | 45d | 2014-02-10 | 2014-03-23 | E.LP.RA.111 SS+10d | 25.5d | 0d | SSH-Construction Manhours [1800 h] | Z3 |
| E.LP.RC.111 |  | Balance LV Cable Installation - Road C |  | 45d | 2014-02-10 | 2014-03-23 | E.LP.RA.121 SS | 25.5d | 0d | SSH-Construction Manhours [480 h] | Z2 |
| E.LP.RC.121 |  | Lighting pole/fixtures Balance Work - Road C |  | 30d | 2014-02-24 | 2014-03-23 | E.LP.RC.111 SS+15d | 65.5d | 0d | SSH-Construction Manhours [900 h] | Z2 |
| E.PSS.Z3.111 |  | Package Substation installation - Z3 |  | 30d | 2014-03-01 | 2014-03-27 | E.RMU.Z3.111 | 65.5d | 15d | SSH-Construction Manhours [500 h] | Z3 |
| E.RMU.Z2.111 |  | RMU installation - Z2 |  | 45d | 2014-03-01 | 2014-04-10 | E.RMU.Z3.111 | 5.5d | 0d | SSH-Construction Manhours [500 h] | Z2 |
| E.RMU.Z4.111 |  | MV cable installation - Z4 |  | 25d | 2014-03-01 | 2014-03-23 | E.RMU.Z3.111 | 55.5d | 0d | SSH-Construction Manhours [1000 h] | Z4 |
| E.CCTV.Z3.111 |  | CCTV Installation - Z3 |  | 60d | 2014-03-15 | 2014-05-08 | E.LP.RA.111 | 20.5d | 0d | SSH-Construction Manhours [1500 h] | Z3 |
| E.CCTV.Z2.112 |  | CCTV Installation - Z2 (Exc+Fdn+Pole+Accs+BF) |  | 45d | 2014-03-24 | 2014-05-04 | E.LP.RC.111 | 25.5d | 0d | SSH-Construction Manhours [800 h] | Z2 |
| E.LP.RA.131 |  | Testing Lighting - Road A |  | 30d | 2014-03-24 | 2014-04-20 | E.LP.RA.121 | 25.5d | 0d | SSH-Construction Manhours [800 h] | Z3 |
| E.LP.RC.131 |  | Testing Lighting - Road C |  | 20d | 2014-03-24 | 2014-04-10 | E.LP.RC.121 | 65.5d | 0d | SSH-Construction Manhours [800 h] | Z2 |
| E.LP.RD.111 |  | Cable Installation - Road D |  | 20d | 2014-03-24 | 2014-04-10 | E.LP.RC.121 | 65.5d | 0d | SSH-Construction Manhours [800 h] | Z2 |
| E.RMU.Z4.121 |  | RMU installation - Z4 |  | 15d | 2014-03-24 | 2014-04-06 | E.RMU.Z4.111 | 55.5d | 5d | SSH-Construction Manhours [800 h] | Z4 |
| E.LP.RD.131 |  | Testing Lighting - Road D |  | 15d | 2014-04-12 | 2014-04-24 | E.LP.RD.111, E.LP.RC.131 | 65.5d | 60d | SSH-Construction Manhours [600 h] | Z2 |
| E.PSS.Z2.111 |  | Package Substation installation - Z2 |  | 15d | 2014-04-12 | 2014-04-24 | E.RMU.Z2.111 | 35.5d | 0d | SSH-Construction Manhours [400 h] | Z2 |
| E.RMU.Z4.131 |  | MV Cable Installation - Fence to SEC |  | 45d | 2014-04-12 | 2014-05-22 | E.RMU.Z3.111, E.RMU.Z2.111 | 5.5d | 0d | SSH-Construction Manhours [1500 h] | Z2 |
| E.RMU.Z4.141 |  | Pre-Commissionig of RMU |  | 30d | 2014-04-12 | 2014-05-08 | E.RMU.Z4.121, E.RMU.Z2.111, E.PSS.Z3.111 | 50.5d | 45d | SSH-Construction Manhours [600 h] | Z3 |
| E.LP.RB.131 |  | Testing Lighting - Road B |  | 15d | 2014-04-21 | 2014-05-04 | E.LP.RA.131 | 25.5d | 5d | SSH-Construction Manhours [800 h] | Z3 |
| E.RMU.Z4.151 |  | Pre-Commissionig of Package Substation |  | 30d | 2014-04-26 | 2014-05-22 | E.PSS.Z2.111, E.PSS.Z3.111 | 35.5d | 30d | SSH-Construction Manhours [400 h] | Z3 |
| E.CCTV.Z2.111 |  | Code Blue Installation - Z2 |  | 30d | 2014-05-05 | 2014-06-01 | E.CCTV.Z2.112 | 25.5d | 20d | SSH-Construction Manhours [800 h] | Z2 |
| E.CCTV.Z4.111 |  | CCTV Installation - Z4 |  | 30d | 2014-05-10 | 2014-06-05 | E.LP.RB.131, E.CCTV.Z3.111 | 20.5d | 15d | SSH-Construction Manhours [1800 h] | Z4 |
| E.RMU.Z4.161 |  | Pre-Commissionig of MV Cable |  | 30d | 2014-05-24 | 2014-06-19 | E.RMU.Z4.131, E.RMU.Z4.111 | 5.5d | 0d | SSH-Construction Manhours [800 h] | Z3 |
| E.Works.999 |  | Electrical Works Finish | milestone | 0d | 2014-06-19 | 2014-06-19 | E.RMU.Z4.151, E.RMU.Z4.161, E.CCTV.Z4.111, E.PSS.Z2.111, E.CCTV.Z2.111, E.RMU.Z4.131, E.LP.RD.131, E.CCTV.Z2.112, E.PSS.Z3.111, E.RMU.Z4.121, E.LP.RB.131, E.RMU.Z4.141, E.LP.RC.131 | 5.5d | 1d |  | Z3 |

| ID | WBS | Activity | Type | Duration | Start | Finish | Predecessors | Total float | Free float | Resources | Department |
| --- | --- | --- | --- | --- | --- | --- | --- | --- | --- | --- | --- |
|  | 16 | **Telecomm Works** |  |  | 2014-02-01 | 2014-06-21 |  |  |  |  |  |
| COM.Z2.111 |  | Manhole Installation -Z2 |  | 15d | 2014-02-01 | 2014-02-13 | COM.Z3.121 SS | 4.5d | 0d | SSH-Construction Manhours [1000 h] | Z2 |
| COM.Z3.121 |  | Sub-duct pulling -Z3 |  | 30d | 2014-02-01 | 2014-02-27 | Eng.110 SS | 4.5d | 0d | SSH-Construction Manhours [1500 h] | Z3 |
| COM.Z4.111 |  | Manhole Installation -Z4 |  | 30d | 2014-02-01 | 2014-02-27 | COM.Z3.121 SS | 5.5d | 0d | SSH-Construction Manhours [800 h] | Z4 |
| COM.Z2.121 |  | Ductbank construction -Z2 |  | 25d | 2014-02-15 | 2014-03-09 | COM.Z2.111 | 4.5d | 0d | SSH-Construction Manhours [1800 h] | Z2 |
| COM.CB.111 |  | CODE BLUE / IPCCTV Ductbank construction |  | 30d | 2014-02-17 | 2014-03-17 | COM.Z2.121 SS+3d | 6.5d | 0d | SSH-Construction Manhours [2000 h] | Z3 |
| COM.CB.112 |  | Code Blue Foundation & Padstal Installation |  | 30d | 2014-02-26 | 2014-03-26 | COM.CB.111 SS+10d | 6.5d | 2d | SSH-Construction Manhours [1000 h] | Z3 |
| COM.K.111 |  | Ductbank construction - Inside KAUST |  | 30d | 2014-03-01 | 2014-03-27 | COM.Z2.121 SS+15d | 4.5d | 0d | SSH-Construction Manhours [3000 h] | Z3 |
| COM.Z3.131 |  | Copper cable pulling -Z3 |  | 45d | 2014-03-01 | 2014-04-10 | COM.Z3.121 | 10.5d | 0d | SSH-Construction Manhours [1500 h] | Z3 |
| COM.Z4.121 |  | Ductbank construction -Z4 |  | 30d | 2014-03-01 | 2014-03-27 | COM.Z4.111 | 5.5d | 0d | SSH-Construction Manhours [800 h] | Z4 |
| COM.Z2.131 |  | Sub-duct pulling -Z2 |  | 25d | 2014-03-10 | 2014-04-01 | COM.Z2.121 | 15.5d | 0d | SSH-Construction Manhours [1500 h] | Z2 |
| COM.CB.113 |  | IPCCTV Pole & camera installation |  | 30d | 2014-03-17 | 2014-04-14 | COM.CB.112 SS, COM.CB.111 | 6.5d | 2d | SSH-Construction Manhours [1000 h] | Z3 |
| COM.K.121 |  | Sub-duct pulling - Inside KAUST |  | 25d | 2014-03-29 | 2014-04-20 | COM.CB.112, COM.K.111 | 4.5d | 0d | SSH-Construction Manhours [1500 h] | Z3 |
| COM.Z4.131 |  | Sub-duct pulling -Z4 |  | 20d | 2014-03-29 | 2014-04-15 | COM.Z4.121 | 5.5d | 0d | SSH-Construction Manhours [800 h] | Z4 |
| COM.Z2.141 |  | Copper cable pulling -Z2 |  | 25d | 2014-04-02 | 2014-04-24 | COM.Z2.131 | 15.5d | 0d | SSH-Construction Manhours [1500 h] | Z2 |
| COM.Z3.141 |  | FOC pulling -Z3 |  | 45d | 2014-04-12 | 2014-05-22 | COM.Z3.131 | 10.5d | 5d | SSH-Construction Manhours [1500 h] | Z3 |
| COM.K.131 |  | Copper cable pulling - Inside KAUST |  | 25d | 2014-04-16 | 2014-05-08 | COM.K.121 SS+20d, COM.CB.113 | 4.5d | 0d | SSH-Construction Manhours [1500 h] | Z3 |
| COM.Z4.141 |  | Copper cable pulling -Z4 |  | 20d | 2014-04-16 | 2014-05-04 | COM.Z4.131 | 5.5d | 0d | SSH-Construction Manhours [800 h] | Z4 |
| COM.K.141 |  | FOC pulling - Inside KAUST |  | 25d | 2014-04-21 | 2014-05-14 | COM.K.131 SS+6d | 4.5d | 0d | SSH-Construction Manhours [1500 h] | Z3 |
| COM.Z2.151 |  | FOC pulling -Z2 |  | 25d | 2014-04-26 | 2014-05-18 | COM.Z2.141 | 40.5d | 36d | SSH-Construction Manhours [800 h] | Z2 |
| COM.PC.111 |  | Copper Cable Splicing - Termination |  | 25d | 2014-05-05 | 2014-05-27 | COM.Z2.141, COM.Z3.131, COM.Z4.141 | 5.5d | 0d | SSH-Construction Manhours [500 h] | Z3 |
| COM.Z4.151 |  | FOC pulling -Z4 |  | 20d | 2014-05-05 | 2014-05-22 | COM.Z4.141 | 10.5d | 5d | SSH-Construction Manhours [800 h] | Z4 |
| COM.PC.113 |  | Copper Cable Testing - Commissioning |  | 25d | 2014-05-14 | 2014-06-07 | COM.K.141 | 4.5d | 0d | SSH-Construction Manhours [500 h] | Z3 |
| COM.PC.112 |  | FOC Splicing - Termination |  | 25d | 2014-05-28 | 2014-06-19 | COM.PC.111, COM.Z4.151, COM.Z3.141 | 5.5d | 1d | SSH-Construction Manhours [500 h] | Z3 |
| COM.PC.114 |  | FOC Testing - Commissioning |  | 15d | 2014-06-07 | 2014-06-21 | COM.PC.113 | 4.5d | 0d | SSH-Construction Manhours [500 h] | Z3 |
| TCOM.999 |  | Telecomm Works Finish | milestone | 0d | 2014-06-21 | 2014-06-21 | COM.PC.114, COM.Z4.151, E.Works.999, COM.Z2.151, COM.K.141, COM.PC.112, COM.Z3.141, COM.CB.113 | 4.5d | 0d |  | Z3 |

| ID | WBS | Activity | Type | Duration | Start | Finish | Predecessors | Total float | Free float | Resources | Department |
| --- | --- | --- | --- | --- | --- | --- | --- | --- | --- | --- | --- |
|  | 17 | **Substation - 4** |  |  | 2014-02-01 | 2014-07-13 |  |  |  |  |  |
| SS4.310 |  | Ducting Works |  | 30d | 2014-02-01 | 2014-02-27 | Eng.110 SS | 10.5d | 0d | SSH-Construction Manhours [1000 h] | Z3 |
| SS4.101 |  | Ceiling Finishing works |  | 15d | 2014-03-01 | 2014-03-13 | SS4.310 | 35.5d | 0d | SSH-Construction Manhours [600 h] | Z3 |
| SS4.320 |  | Inlet & outlet accs. |  | 15d | 2014-03-01 | 2014-03-13 | SS4.310 | 10.5d | 0d | SSH-Construction Manhours [500 h] | Z3 |
| SS4.111 |  | Painting works |  | 15d | 2014-03-15 | 2014-03-27 | SS4.101 | 35.5d | 0d | SSH-Construction Manhours [1200 h] | Z3 |
| SS4.330 |  | Fire & Volume dampers |  | 15d | 2014-03-15 | 2014-03-27 | SS4.320 | 10.5d | 0d | SSH-Construction Manhours [500 h] | Z3 |
| SS4.400 |  | Electrical Conduits |  | 15d | 2014-03-15 | 2014-03-27 | SS4.330 FF | 10.5d | 0d | SSH-Construction Manhours [1200 h] | Z3 |
| SS4.121 |  | Doors & windows |  | 15d | 2014-03-29 | 2014-04-10 | SS4.111 | 35.5d | 0d | SSH-Construction Manhours [1200 h] | Z3 |
| SS4.340 |  | Sandtrap louvers installed RFI balance |  | 15d | 2014-03-29 | 2014-04-10 | SS4.330 | 10.5d | 0d | SSH-Construction Manhours [750 h] | Z3 |
| SS4.410 |  | Electrical Cables & wires |  | 15d | 2014-03-29 | 2014-04-10 | SS4.400 | 10.5d | 0d | SSH-Construction Manhours [2250 h] | Z3 |
| SS4.510 |  | Commmunication conduits |  | 15d | 2014-03-29 | 2014-04-10 | SS4.400 | 40.5d | 0d | SSH-Construction Manhours [1200 h] | Z3 |
| SS4.131 |  | Gravel Pavement |  | 15d | 2014-04-12 | 2014-04-24 | SS4.121 | 35.5d | 0d | SSH-Construction Manhours [3000 h] | Z3 |
| SS4.350 |  | Exhaust fans |  | 10d | 2014-04-12 | 2014-04-20 | SS4.340 | 10.5d | 0d | SSH-Construction Manhours [800 h] | Z3 |
| SS4.420 |  | Lighitng Fixtures |  | 10d | 2014-04-12 | 2014-04-20 | SS4.410 | 10.5d | 0d | SSH-Construction Manhours [800 h] | Z3 |
| SS4.520 |  | Comm Data Networks system |  | 10d | 2014-04-12 | 2014-04-20 | SS4.510 | 40.5d | 0d | SSH-Construction Manhours [800 h] | Z3 |
| SS4.360 |  | DDC Panel - installed - RFI balance |  | 10d | 2014-04-21 | 2014-04-29 | SS4.350 | 10.5d | 0d | SSH-Construction Manhours [800 h] | Z3 |
| SS4.430 |  | Fire Alarm system & Fire Alarm control Panel |  | 10d | 2014-04-21 | 2014-04-29 | SS4.420 | 10.5d | 0d | SSH-Construction Manhours [800 h] | Z3 |
| SS4.530 |  | Communication cabinet accs |  | 10d | 2014-04-21 | 2014-04-29 | SS4.520 | 40.5d | 0d | SSH-Construction Manhours [800 h] | Z3 |
| SS4.141 |  | Curb stones |  | 10d | 2014-04-26 | 2014-05-04 | SS4.131 | 35.5d | 0d | SSH-Construction Manhours [1000 h] | Z3 |
| SS4.151 |  | Perimeter Fence |  | 25d | 2014-04-26 | 2014-05-18 | SS4.141 SS | 35.5d | 0d | SSH-Construction Manhours [1000 h] | Z3 |
| SS4.210 |  | Plumbing works, Eye wash & shower |  | 15d | 2014-04-26 | 2014-05-08 | SS4.131 | 45.5d | 10d | SSH-Construction Manhours [1500 h] | Z3 |
| SS4.370 |  | AHU (Air Handling Unit) |  | 10d | 2014-04-30 | 2014-05-08 | SS4.360 | 10.5d | 0d | SSH-Construction Manhours [800 h] | Z3 |
| SS4.440 |  | Switchboards & outlets |  | 10d | 2014-04-30 | 2014-05-08 | SS4.430 | 10.5d | 0d | SSH-Construction Manhours [800 h] | Z3 |
| SS4.540 |  | Communication equipments |  | 10d | 2014-04-30 | 2014-05-08 | SS4.530 | 40.5d | 0d | SSH-Construction Manhours [1500 h] | Z3 |
| SS4.380 |  | ACCU (Air Cooled Condencing unit) |  | 10d | 2014-05-10 | 2014-05-18 | SS4.370 | 10.5d | 0d | SSH-Construction Manhours [800 h] | Z3 |
| SS4.450 |  | Battery bank & battery chargers |  | 10d | 2014-05-10 | 2014-05-18 | SS4.440 | 10.5d | 0d | SSH-Construction Manhours [800 h] | Z3 |
| SS4.550 |  | Comm outlets accs |  | 10d | 2014-05-10 | 2014-05-18 | SS4.540 | 40.5d | 0d | SSH-Construction Manhours [800 h] | Z3 |
| SS4.161 |  | Asphalt Pavement |  | 25d | 2014-05-19 | 2014-06-10 | SS4.151, SS4.210 | 35.5d | 0d | SSH-Construction Manhours [1500 h] | Z3 |
| SS4.390 |  | Testing & Balancing of HVAC system |  | 60d | 2014-05-19 | 2014-07-13 | SS4.380 | 10.5d | 0d | SSH-Construction Manhours [600 h] | Z3 |
| SS4.460 |  | Testing of Electrical system SS4 |  | 60d | 2014-05-19 | 2014-07-13 | SS4.450, SS4.440 | 10.5d | 0d | SSH-Construction Manhours [1500 h] | Z3 |
| SS4.560 |  | Testing of Telecomm system SS4 |  | 30d | 2014-05-19 | 2014-06-15 | SS4.550 | 40.5d | 30d | SSH-Construction Manhours [600 h] | Z3 |
| SS4.171 |  | Road Marking / Road Signage |  | 10d | 2014-06-11 | 2014-06-19 | SS4.161 | 35.5d | 25d | SSH-Construction Manhours [2000 h] | Z3 |
| SS4.999 |  | Substation 4 Finish | milestone | 0d | 2014-07-13 | 2014-07-13 | SS4.460, SS4.450, SS4.171, SS4.390, SS4.560, SS4.210 | 10.5d | 0d |  | Z3 |

Notes:
- SS4.330: Anticipated Problems: Material is not accepted, normal ETA 4-6 weeks / Register is also not accepted, shelf item.
- SS4.340: Anticipated Problems: Sandtrap louvers installed - RFI balance
- SS4.350: Anticipated Problems: Ventilation calculation have been submitted
- SS4.360: Anticipated Problems: DDC Panel installed - RFI balance

| ID | WBS | Activity | Type | Duration | Start | Finish | Predecessors | Total float | Free float | Resources | Department |
| --- | --- | --- | --- | --- | --- | --- | --- | --- | --- | --- | --- |
|  | 18 | **Substation - 5** |  |  | 2014-02-01 | 2014-06-29 |  |  |  |  |  |
| SS5.310 |  | Ducting Works |  | 15d | 2014-02-01 | 2014-02-13 | Eng.110 SS | 0.5d | 0d | SSH-Construction Manhours [1000 h] | Z3 |
| SS5.101 |  | Ceiling Finishing works |  | 15d | 2014-02-15 | 2014-02-27 | SS5.310 | 25.5d | 0d | SSH-Construction Manhours [600 h] | Z3 |
| SS5.320 |  | Inlet & outlet accs. |  | 15d | 2014-02-15 | 2014-02-27 | SS5.310 | 0.5d | 0d | SSH-Construction Manhours [500 h] | Z3 |
| SS5.111 |  | Painting works |  | 15d | 2014-03-01 | 2014-03-13 | SS5.101 | 25.5d | 0d | SSH-Construction Manhours [1200 h] | Z3 |
| SS5.330 |  | Fire & Volume dampers |  | 15d | 2014-03-01 | 2014-03-13 | SS5.320 | 0.5d | 0d | SSH-Construction Manhours [500 h] | Z3 |
| SS5.400 |  | Electrical Conduits |  | 15d | 2014-03-01 | 2014-03-13 | SS5.330 FF | 0.5d | 0d | SSH-Construction Manhours [1200 h] | Z3 |
| SS5.121 |  | Doors & windows |  | 15d | 2014-03-15 | 2014-03-27 | SS5.111 | 25.5d | 0d | SSH-Construction Manhours [500 h] | Z3 |
| SS5.340 |  | Sandtrap louvers installed RFI balance |  | 15d | 2014-03-15 | 2014-03-27 | SS5.330 | 15.5d | 0d | SSH-Construction Manhours [750 h] | Z3 |
| SS5.410 |  | Electrical Cables & wires |  | 15d | 2014-03-15 | 2014-03-27 | SS5.400 | 0.5d | 0d | SSH-Construction Manhours [800 h] | Z3 |
| SS5.510 |  | Commmunication conduits |  | 15d | 2014-03-15 | 2014-03-27 | SS5.400 | 0.5d | 0d | SSH-Construction Manhours [1200 h] | Z3 |
| SS5.131 |  | Gravel Pavement |  | 15d | 2014-03-29 | 2014-04-10 | SS5.121 | 25.5d | 0d | SSH-Construction Manhours [800 h] | Z3 |
| SS5.350 |  | Exhaust fans |  | 10d | 2014-03-29 | 2014-04-06 | SS5.340 | 15.5d | 0d | SSH-Construction Manhours [800 h] | Z3 |
| SS5.420 |  | Lighitng Fixtures |  | 10d | 2014-03-29 | 2014-04-06 | SS5.410 | 0.5d | 0d | SSH-Construction Manhours [400 h] | Z3 |
| SS5.520 |  | Comm Data Networks system |  | 10d | 2014-03-29 | 2014-04-06 | SS5.510 | 0.5d | 0d | SSH-Construction Manhours [800 h] | Z3 |
| SS5.360 |  | DDC Panel - installed - RFI balance |  | 10d | 2014-04-07 | 2014-04-15 | SS5.350 | 15.5d | 0d | SSH-Construction Manhours [800 h] | Z3 |
| SS5.430 |  | Fire Alarm system & Fire Alarm control Panel |  | 10d | 2014-04-07 | 2014-04-15 | SS5.420 | 0.5d | 0d | SSH-Construction Manhours [400 h] | Z3 |
| SS5.530 |  | Communication cabinet accs |  | 10d | 2014-04-07 | 2014-04-15 | SS5.520 | 0.5d | 0d | SSH-Construction Manhours [800 h] | Z3 |
| SS5.141 |  | Curb stones |  | 10d | 2014-04-12 | 2014-04-20 | SS5.131 | 25.5d | 0d | SSH-Construction Manhours [1000 h] | Z3 |
| SS5.151 |  | Perimeter Fence |  | 25d | 2014-04-12 | 2014-05-04 | SS5.141 SS | 25.5d | 0d | SSH-Construction Manhours [1000 h] | Z3 |
| SS5.210 |  | Plumbing works, Eye wash & shower |  | 15d | 2014-04-12 | 2014-04-24 | SS5.131 | 35.5d | 10d | SSH-Construction Manhours [500 h] | Z3 |
| SS5.370 |  | AHU (Air Handling Unit) |  | 10d | 2014-04-16 | 2014-04-24 | SS5.360 | 15.5d | 0d | SSH-Construction Manhours [800 h] | Z3 |
| SS5.440 |  | Switchboards & outlets |  | 10d | 2014-04-16 | 2014-04-24 | SS5.430 | 0.5d | 0d | SSH-Construction Manhours [400 h] | Z3 |
| SS5.540 |  | Communication equipments |  | 10d | 2014-04-16 | 2014-04-24 | SS5.530 | 0.5d | 0d | SSH-Construction Manhours [1500 h] | Z3 |
| SS5.380 |  | ACCU (Air Cooled Condencing unit) |  | 10d | 2014-04-26 | 2014-05-04 | SS5.370 | 15.5d | 0d | SSH-Construction Manhours [800 h] | Z3 |
| SS5.450 |  | Battery bank & battery chargers |  | 10d | 2014-04-26 | 2014-05-04 | SS5.440 | 0.5d | 0d | SSH-Construction Manhours [800 h] | Z3 |
| SS5.550 |  | Comm outlets accs |  | 10d | 2014-04-26 | 2014-05-04 | SS5.540 | 0.5d | 0d | SSH-Construction Manhours [800 h] | Z3 |
| SS5.161 |  | Asphalt Pavement |  | 25d | 2014-05-05 | 2014-05-27 | SS5.210, SS5.151 | 25.5d | 0d | SSH-Construction Manhours [1500 h] | Z3 |
| SS5.390 |  | Testing & Balancing of HVAC system |  | 45d | 2014-05-05 | 2014-06-15 | SS5.380 | 15.5d | 15d | SSH-Construction Manhours [600 h] | Z3 |
| SS5.460 |  | Testing of Electrical system SS5 |  | 60d | 2014-05-05 | 2014-06-29 | SS5.440, SS5.450, SS5.550 | 0.5d | 0d | SSH-Construction Manhours [1500 h] | Z3 |
| SS5.560 |  | Testing of Telecomm system SS5 |  | 30d | 2014-05-05 | 2014-06-01 | SS5.550 | 30.5d | 30d | SSH-Construction Manhours [600 h] | Z3 |
| SS5.171 |  | Road Marking / Road Signage |  | 10d | 2014-05-28 | 2014-06-05 | SS5.161 | 25.5d | 25d | SSH-Construction Manhours [600 h] | Z3 |
| SS5.999 |  | Substation 5 Finish | milestone | 0d | 2014-06-29 | 2014-06-29 | SS5.390, SS5.460, SS5.210, SS5.450, SS5.171, SS5.560 | 0.5d | 0d |  | Z3 |

Notes:
- SS5.330: Anticipated Problems: Material is not accepted, normal ETA 4-6 weeks / Register is also not accepted, shelf item.
- SS5.340: Anticipated Problems: Sandtrap louvers installed - RFI balance
- SS5.350: Anticipated Problems: Ventilation calculation have been submitted
- SS5.360: Anticipated Problems: DDC Panel installed - RFI balance

| ID | WBS | Activity | Type | Duration | Start | Finish | Predecessors | Total float | Free float | Resources | Department |
| --- | --- | --- | --- | --- | --- | --- | --- | --- | --- | --- | --- |
|  | 19 | **AEB-Alternate Exchange Building** |  |  | 2014-02-01 | 2014-11-20 |  |  |  |  |  |
| AEB.101 |  | Structural Steel |  | 15d | 2014-02-01 | 2014-02-13 | SS5.310 SS | 0.5d | 0d | SSH-Construction Manhours [2000 h] | Z3 |
| AEB.110 |  | Roof Water proofing |  | 15d | 2014-02-15 | 2014-02-27 | AEB.101 | 0.5d | 0d | SSH-Construction Manhours [800 h] | Z3 |
| AEB.111 |  | Block Works |  | 15d | 2014-03-01 | 2014-03-13 | AEB.110 | 0.5d | 0d | SSH-Construction Manhours [800 h] | Z3 |
| AEB.121 |  | Plastering |  | 25d | 2014-03-15 | 2014-04-06 | AEB.111 | 0.5d | 0d | SSH-Construction Manhours [1000 h] | Z3 |
| AEB.301 |  | HVAC Ducting sytem |  | 30d | 2014-03-15 | 2014-04-10 | AEB.111 | 18.5d | 0d | SSH-Construction Manhours [800 h] | Z3 |
| AEB.401 |  | Electrical conduits |  | 25d | 2014-03-19 | 2014-04-12 | AEB.301 SS+6d | 18.5d | 0d | SSH-Construction Manhours [800 h] | Z3 |
| AEB.131 |  | Floor Slab |  | 35d | 2014-04-07 | 2014-05-08 | AEB.121 | 0.5d | 0d | SSH-Construction Manhours [1000 h] | Z3 |
| AEB.311 |  | Fire & volume dampers |  | 30d | 2014-04-12 | 2014-05-08 | AEB.301 | 30.5d | 0d | SSH-Construction Manhours [600 h] | Z3 |
| AEB.402 |  | Electrical cables |  | 25d | 2014-04-12 | 2014-05-05 | AEB.401 | 18.5d | 0d | SSH-Construction Manhours [800 h] | Z3 |
| AEB.141 |  | Dry Wall Partitioning |  | 30d | 2014-04-26 | 2014-05-22 | AEB.131 SS+20d | 0.5d | 0d | SSH-Construction Manhours [1200 h] | Z3 |
| AEB.321 |  | Air inlet & outlets |  | 30d | 2014-04-26 | 2014-05-22 | AEB.311 SS+15d | 30.5d | 0d | SSH-Construction Manhours [600 h] | Z3 |
| AEB.403 |  | Lighting fixtures |  | 15d | 2014-05-05 | 2014-05-19 | AEB.402 | 18.5d | 0d | SSH-Construction Manhours [600 h] | Z3 |
| AEB.331 |  | Sand trap louvers |  | 30d | 2014-05-10 | 2014-06-05 | AEB.321 SS+15d | 30.5d | 0d | SSH-Construction Manhours [600 h] | Z3 |
| AEB.421 |  | Panel boards |  | 15d | 2014-05-19 | 2014-06-02 | AEB.403 | 18.5d | 0d | SSH-Construction Manhours [600 h] | Z3 |
| AEB.151 |  | Acoustic ceiling works |  | 15d | 2014-05-24 | 2014-06-05 | AEB.141 | 0.5d | 0d | SSH-Construction Manhours [1200 h] | Z3 |
| AEB.422 |  | Annunicator DC distribution panel |  | 15d | 2014-06-02 | 2014-06-16 | AEB.421 | 18.5d | 0d | SSH-Construction Manhours [800 h] | Z3 |
| AEB.161 |  | Wall tiling |  | 25d | 2014-06-07 | 2014-06-29 | AEB.151 | 0.5d | 0d | SSH-Construction Manhours [1200 h] | Z3 |
| AEB.341 |  | Exhaust fans |  | 8d | 2014-06-07 | 2014-06-14 | AEB.331 | 30.5d | 0d | SSH-Construction Manhours [400 h] | Z3 |
| AEB.351 |  | Fire protection system & fire extinguishers |  | 20d | 2014-06-14 | 2014-07-02 | AEB.341 | 30.5d | 0d | SSH-Construction Manhours [800 h] | Z3 |
| AEB.431 |  | Battery bank, battery charger and UPS |  | 15d | 2014-06-16 | 2014-06-30 | AEB.422 | 18.5d | 0d | SSH-Construction Manhours [800 h] | Z3 |
| AEB.501 |  | Install Telecomm equipments and acc in cable vault |  | 30d | 2014-06-21 | 2014-07-19 | TCOM.999 | 4.5d | 0d | SSH-Construction Manhours [1200 h] | Z3 |
| AEB.511 |  | Install MDF |  | 30d | 2014-06-21 | 2014-07-19 | AEB.501 SS | 4.5d | 0d | SSH-Construction Manhours [800 h] | Z3 |
| AEB.171 |  | Floor tiling |  | 25d | 2014-06-30 | 2014-07-22 | SS5.999, AEB.161 | 0.5d | 0d | SSH-Construction Manhours [1200 h] | Z3 |
| AEB.441 |  | Inverters and Inverter distribution panel |  | 15d | 2014-06-30 | 2014-07-14 | AEB.431 | 18.5d | 0d | SSH-Construction Manhours [800 h] | Z3 |
| AEB.361 |  | Install ACCU |  | 15d | 2014-07-02 | 2014-07-16 | AEB.351 | 30.5d | 0d | SSH-Construction Manhours [800 h] | Z3 |
| AEB.521 |  | Install SACS System |  | 30d | 2014-07-05 | 2014-08-02 | AEB.511 SS+15d | 4.5d | 0d | SSH-Construction Manhours [1200 h] | Z3 |
| AEB.442 |  | Disconnect switches |  | 6d | 2014-07-14 | 2014-07-20 | AEB.441 | 18.5d | 0d | SSH-Construction Manhours [600 h] | Z3 |
| AEB.371 |  | Install AHU |  | 15d | 2014-07-16 | 2014-07-30 | AEB.361 | 30.5d | 0d | SSH-Construction Manhours [800 h] | Z3 |
| AEB.531 |  | Install IPTV system |  | 30d | 2014-07-19 | 2014-08-16 | AEB.521 SS+15d | 4.5d | 0d | SSH-Construction Manhours [1200 h] | Z3 |
| AEB.451 |  | Fire alarm system |  | 25d | 2014-07-20 | 2014-08-12 | AEB.442 | 18.5d | 0d | SSH-Construction Manhours [800 h] | Z3 |
| AEB.181 |  | Doors & Windows |  | 30d | 2014-07-23 | 2014-08-19 | AEB.171, SS4.999 | 0.5d | 0d | SSH-Construction Manhours [800 h] | Z3 |
| AEB.191 |  | Plumbing fixtures |  | 20d | 2014-07-23 | 2014-08-10 | AEB.181 SS | 0.5d | 0d | SSH-Construction Manhours [800 h] | Z3 |
| AEB.201 |  | Geneal fill around AEB |  | 20d | 2014-07-23 | 2014-08-10 | AEB.191 SS | 0.5d | 0d | SSH-Construction Manhours [900 h] | Z3 |
| AEB.381 |  | Testing & balancing of HVAC system |  | 30d | 2014-07-30 | 2014-08-27 | AEB.371 | 30.5d | 12d | SSH-Construction Manhours [2000 h] | Z3 |
| AEB.541 |  | Install CCTV system |  | 30d | 2014-08-02 | 2014-08-30 | AEB.531 SS+15d | 4.5d | 0d | SSH-Construction Manhours [1200 h] | Z3 |
| AEB.211 |  | Base course around AEB |  | 20d | 2014-08-11 | 2014-08-28 | AEB.201 | 0.5d | 0d | SSH-Construction Manhours [900 h] | Z3 |
| AEB.452 |  | Fire alarm control panel |  | 10d | 2014-08-12 | 2014-08-21 | AEB.451 | 18.5d | 0d | SSH-Construction Manhours [400 h] | Z3 |
| AEB.551 |  | Install Telecomm outlets / accs |  | 30d | 2014-08-16 | 2014-09-13 | AEB.541 SS+15d | 4.5d | 0d | SSH-Construction Manhours [500 h] | Z3 |
| AEB.461 |  | Circuit breakers |  | 10d | 2014-08-21 | 2014-08-31 | AEB.452 | 18.5d | 0d | SSH-Construction Manhours [400 h] | Z3 |
| AEB.215 |  | Curbstone around AEB |  | 15d | 2014-08-30 | 2014-09-11 | PC.191, AEB.211 | 0.5d | 0d | SSH-Construction Manhours [600 h] | Z3 |
| AEB.561 |  | Install telecomm equ to connect with existing bldg |  | 25d | 2014-08-30 | 2014-09-22 | AEB.551 SS+15d | 4.5d | 0d | SSH-Construction Manhours [400 h] | Z3 |
| AEB.462 |  | Install ATS |  | 8d | 2014-08-31 | 2014-09-07 | AEB.461 | 18.5d | 0d | SSH-Construction Manhours [400 h] | Z3 |
| AEB.463 |  | Moduler rectifier |  | 8d | 2014-09-08 | 2014-09-15 | AEB.381, AEB.462 | 18.5d | 0d | SSH-Construction Manhours [400 h] | Z3 |
| AEB.221 |  | Lighting pole fdns around AEB |  | 10d | 2014-09-13 | 2014-09-21 | AEB.215 | 0.5d | 0d | SSH-Construction Manhours [600 h] | Z3 |
| AEB.571 |  | Install telecomm equ to connect with security HQ |  | 25d | 2014-09-13 | 2014-10-06 | AEB.561 SS+15d | 4.5d | 0d | SSH-Construction Manhours [400 h] | Z3 |
| AEB.471 |  | Install Generator |  | 8d | 2014-09-15 | 2014-09-22 | AEB.463 | 18.5d | 0d | SSH-Construction Manhours [400 h] | Z3 |
| AEB.231 |  | Gravel pavement around AEB |  | 20d | 2014-09-22 | 2014-10-09 | AEB.221 | 0.5d | 0d | SSH-Construction Manhours [600 h] | Z3 |
| AEB.472 |  | Install Transformer |  | 8d | 2014-09-22 | 2014-09-30 | AEB.471 | 18.5d | 0d | SSH-Construction Manhours [400 h] | Z3 |
| AEB.581 |  | Install telecomm equ to connect with bsns data center |  | 25d | 2014-09-27 | 2014-10-20 | AEB.571 SS+15d | 4.5d | 0d | SSH-Construction Manhours [400 h] | Z3 |
| AEB.473 |  | Install Switchboards |  | 8d | 2014-09-30 | 2014-10-07 | AEB.472 | 18.5d | 0d | SSH-Construction Manhours [400 h] | Z3 |
| AEB.491 |  | Testing & commissioning of Electrical system |  | 30d | 2014-10-07 | 2014-11-04 | AEB.473 | 18.5d | 18d | SSH-Construction Manhours [600 h] | Z3 |
| AEB.232 |  | Install lighting poles & fixtures |  | 10d | 2014-10-11 | 2014-10-19 | AEB.231 | 0.5d | 0d | SSH-Construction Manhours [600 h] | Z3 |
| AEB.241 |  | Asphalt pavement around AEB |  | 20d | 2014-10-20 | 2014-11-06 | AEB.232 | 0.5d | 0d | SSH-Construction Manhours [800 h] | Z3 |
| AEB.591 |  | Testing & commissioning of Telecomm system |  | 30d | 2014-10-20 | 2014-11-17 | AEB.581 | 4.5d | 4d | SSH-Construction Manhours [600 h] | Z3 |
| AEB.251 |  | Road marking / Road Signs |  | 10d | 2014-11-08 | 2014-11-16 | AEB.241 | 0.5d | 0d | SSH-Construction Manhours [500 h] | Z3 |
| AEB.261 |  | Perimeter fence & gate around AEB |  | 15d | 2014-11-08 | 2014-11-20 | AEB.251 SS | 0.5d | 0d | SSH-Construction Manhours [1200 h] | Z3 |
| AEB.999 |  | Alternate Exchange Building Finish | milestone | 0d | 2014-11-20 | 2014-11-20 | AEB.381, AEB.491, AEB.261, AEB.591 | 0.5d | 0d |  | Z3 |

| ID | WBS | Activity | Type | Duration | Start | Finish | Predecessors | Total float | Free float | Resources | Department |
| --- | --- | --- | --- | --- | --- | --- | --- | --- | --- | --- | --- |
|  | 20 | **Toilet # 1** |  |  | 2014-02-01 | 2014-10-14 |  |  |  |  |  |
| T1.111 |  | Block works |  | 21d | 2014-02-01 | 2014-02-19 | Eng.110 SS | 1.5d | 0d | SSH-Construction Manhours [800 h] | Z3 |
| T1.121 |  | Plastering works |  | 21d | 2014-02-19 | 2014-03-11 | T1.111 | 1.5d | 0d | SSH-Construction Manhours [800 h] | Z3 |
| T1.131 |  | Roof waterproofing works |  | 10d | 2014-03-11 | 2014-03-20 | T1.121 | 1.5d | 0d | SSH-Construction Manhours [400 h] | Z3 |
| T1.132 |  | Underground utilities |  | 15d | 2014-03-20 | 2014-04-03 | T1.131 | 1.5d | 0d | SSH-Construction Manhours [600 h] | Z3 |
| T1.141 |  | Floor slab (Slab on grade) |  | 21d | 2014-04-03 | 2014-04-23 | T1.132, T1.121 | 1.5d | 0d | SSH-Construction Manhours [800 h] | Z3 |
| T1.151 |  | Wall tiling |  | 30d | 2014-04-23 | 2014-05-21 | T1.141 | 1.5d | 0d | SSH-Construction Manhours [600 h] | Z3 |
| T1.161 |  | Floor Tiling |  | 21d | 2014-05-21 | 2014-06-10 | T1.151 | 1.5d | 0d | SSH-Construction Manhours [600 h] | Z3 |
| T1.171 |  | Ceiling works |  | 15d | 2014-06-10 | 2014-06-24 | T1.161 | 1.5d | 0d | SSH-Construction Manhours [600 h] | Z3 |
| T1.181 |  | Painting works |  | 15d | 2014-06-24 | 2014-07-08 | T1.171 | 1.5d | 0d | SSH-Construction Manhours [600 h] | Z3 |
| T1.191 |  | Doors & frame |  | 15d | 2014-07-08 | 2014-07-22 | T1.181 | 1.5d | 0d | SSH-Construction Manhours [500 h] | Z3 |
| T1.201 |  | Toilet fixtures |  | 30d | 2014-07-22 | 2014-08-19 | T1.191 | 1.5d | 0d | SSH-Construction Manhours [500 h] | Z3 |
| T1.211 |  | Electrical Conduits |  | 30d | 2014-07-22 | 2014-08-19 | T1.201 SS | 1.5d | 0d | SSH-Construction Manhours [300 h] | Z3 |
| T1.221 |  | Cables / wires |  | 30d | 2014-07-22 | 2014-08-19 | T1.211 SS | 1.5d | 0d | SSH-Construction Manhours [300 h] | Z3 |
| T1.231 |  | Lighting fixtures / outlets |  | 15d | 2014-08-05 | 2014-08-19 | T1.221 SS+15d | 1.5d | 0d | SSH-Construction Manhours [500 h] | Z3 |
| T1.241 |  | Install Panelboard & disconnect switches |  | 15d | 2014-08-19 | 2014-09-02 | T1.231 | 1.5d | 0d | SSH-Construction Manhours [400 h] | Z3 |
| T1.251 |  | Install window AC / Heater |  | 15d | 2014-09-02 | 2014-09-16 | T1.241 | 1.5d | 0d | SSH-Construction Manhours [400 h] | Z3 |
| T1.261 |  | Testing |  | 30d | 2014-09-16 | 2014-10-14 | T1.221, T1.201, T1.251 | 1.5d | 0d | SSH-Construction Manhours [400 h] | Z3 |
| T1.999 |  | Toilet 1 Finish | milestone | 0d | 2014-10-14 | 2014-10-14 | T1.261, T2.999 | 1.5d | 0d |  | Z3 |
|  | 21 | **Toilet # 2** |  |  | 2014-02-01 | 2014-09-23 |  |  |  |  |  |
| T2.111 |  | Block works |  | 10d | 2014-02-01 | 2014-02-09 | T1.111 SS | 23.5d | 0d | SSH-Construction Manhours [800 h] | Z3 |
| T2.121 |  | Plastering works |  | 10d | 2014-02-10 | 2014-02-18 | T2.111 SS+10d | 23.5d | 0d | SSH-Construction Manhours [800 h] | Z3 |
| T2.131 |  | Roof waterproofing works |  | 10d | 2014-02-19 | 2014-02-27 | T2.121 | 23.5d | 0d | SSH-Construction Manhours [400 h] | Z3 |
| T2.132 |  | Undeground utilities |  | 15d | 2014-03-01 | 2014-03-13 | T2.131 | 23.5d | 0d | SSH-Construction Manhours [600 h] | Z3 |
| T2.141 |  | Floor slab (Slab on grade) |  | 21d | 2014-03-15 | 2014-04-02 | T2.132, T2.121 | 23.5d | 0d | SSH-Construction Manhours [800 h] | Z3 |
| T2.151 |  | Wall tiling |  | 30d | 2014-04-02 | 2014-04-30 | T2.141 | 23.5d | 0d | SSH-Construction Manhours [600 h] | Z3 |
| T2.161 |  | Floor tiling |  | 21d | 2014-04-30 | 2014-05-20 | T2.151 | 23.5d | 0d | SSH-Construction Manhours [600 h] | Z3 |
| T2.171 |  | Ceiling works |  | 15d | 2014-05-20 | 2014-06-03 | T2.161 | 23.5d | 0d | SSH-Construction Manhours [600 h] | Z3 |
| T2.181 |  | Painting works |  | 15d | 2014-06-03 | 2014-06-17 | T2.171 | 23.5d | 0d | SSH-Construction Manhours [600 h] | Z3 |
| T2.191 |  | Doors & frame |  | 15d | 2014-06-17 | 2014-07-01 | T2.181 | 23.5d | 0d | SSH-Construction Manhours [500 h] | Z3 |
| T2.201 |  | Toilet fixtures |  | 30d | 2014-07-01 | 2014-07-29 | T2.191 | 23.5d | 0d | SSH-Construction Manhours [500 h] | Z3 |
| T2.211 |  | Electrical Conduits |  | 30d | 2014-07-01 | 2014-07-29 | T2.201 SS | 23.5d | 0d | SSH-Construction Manhours [300 h] | Z3 |
| T2.221 |  | Cables / wires |  | 30d | 2014-07-01 | 2014-07-29 | T2.211 SS | 23.5d | 0d | SSH-Construction Manhours [300 h] | Z3 |
| T2.231 |  | Lighting fixtures / outlets |  | 15d | 2014-07-15 | 2014-07-29 | T2.221 SS+15d | 23.5d | 0d | SSH-Construction Manhours [500 h] | Z3 |
| T2.241 |  | Install Panelboard & disconnect switches |  | 15d | 2014-07-29 | 2014-08-12 | T2.231 | 23.5d | 0d | SSH-Construction Manhours [400 h] | Z3 |
| T2.251 |  | Install window AC / Heater |  | 15d | 2014-08-12 | 2014-08-26 | T2.241 | 23.5d | 0d | SSH-Construction Manhours [400 h] | Z3 |
| T2.261 |  | Testing |  | 30d | 2014-08-26 | 2014-09-23 | T2.251, T2.221, T2.201 | 23.5d | 0d | SSH-Construction Manhours [400 h] | Z3 |
| T2.999 |  | Toilet 2 Finish | milestone | 0d | 2014-09-23 | 2014-09-23 | T3.999, T2.261 | 23.5d | 22d |  | Z3 |

| ID | WBS | Activity | Type | Duration | Start | Finish | Predecessors | Total float | Free float | Resources | Department |
| --- | --- | --- | --- | --- | --- | --- | --- | --- | --- | --- | --- |
|  | 22 | **Toilet # 3** |  |  | 2014-02-01 | 2014-09-23 |  |  |  |  |  |
| T3.111 |  | Block works |  | 10d | 2014-02-01 | 2014-02-09 | T2.111 SS | 23.5d | 0d | SSH-Construction Manhours [800 h] | Z3 |
| T3.121 |  | Plastering works |  | 10d | 2014-02-10 | 2014-02-18 | T3.111 SS+10d | 23.5d | 0d | SSH-Construction Manhours [800 h] | Z3 |
| T3.131 |  | Roof waterproofing works |  | 10d | 2014-02-19 | 2014-02-27 | T3.121 | 23.5d | 0d | SSH-Construction Manhours [400 h] | Z3 |
| T3.132 |  | Underground utilites |  | 15d | 2014-03-01 | 2014-03-13 | T3.131 | 23.5d | 0d | SSH-Construction Manhours [600 h] | Z3 |
| T3.141 |  | Floor slab (Slab on grade) |  | 21d | 2014-03-15 | 2014-04-02 | T3.132, T3.121 | 23.5d | 0d | SSH-Construction Manhours [800 h] | Z3 |
| T3.151 |  | Wall tiling |  | 30d | 2014-04-02 | 2014-04-30 | T3.141 | 23.5d | 0d | SSH-Construction Manhours [600 h] | Z3 |
| T3.161 |  | Floor tiling |  | 21d | 2014-04-30 | 2014-05-20 | T3.151 | 23.5d | 0d | SSH-Construction Manhours [600 h] | Z3 |
| T3.171 |  | Ceiling works |  | 15d | 2014-05-20 | 2014-06-03 | T3.161 | 23.5d | 0d | SSH-Construction Manhours [600 h] | Z3 |
| T3.181 |  | Painting works |  | 15d | 2014-06-03 | 2014-06-17 | T3.171 | 23.5d | 0d | SSH-Construction Manhours [600 h] | Z3 |
| T3.191 |  | Doors & frame |  | 15d | 2014-06-17 | 2014-07-01 | T3.181 | 23.5d | 0d | SSH-Construction Manhours [500 h] | Z3 |
| T3.201 |  | Toilet fixtures |  | 30d | 2014-07-01 | 2014-07-29 | T3.191 | 23.5d | 0d | SSH-Construction Manhours [500 h] | Z3 |
| T3.211 |  | Electrical Conduits |  | 30d | 2014-07-01 | 2014-07-29 | T3.201 SS | 23.5d | 0d | SSH-Construction Manhours [300 h] | Z3 |
| T3.221 |  | Cables / wires |  | 30d | 2014-07-01 | 2014-07-29 | T3.211 SS | 23.5d | 0d | SSH-Construction Manhours [300 h] | Z3 |
| T3.231 |  | Lighting fixtures / outlets |  | 15d | 2014-07-15 | 2014-07-29 | T3.221 SS+15d | 23.5d | 0d | SSH-Construction Manhours [500 h] | Z3 |
| T3.241 |  | Install Panelboard & disconnect switches |  | 15d | 2014-07-29 | 2014-08-12 | T3.231, SB1.999 | 23.5d | 0d | SSH-Construction Manhours [400 h] | Z3 |
| T3.251 |  | Install window AC / Heater |  | 15d | 2014-08-12 | 2014-08-26 | T3.241 | 23.5d | 0d | SSH-Construction Manhours [400 h] | Z3 |
| T3.261 |  | Testing |  | 30d | 2014-08-26 | 2014-09-23 | T3.201, T3.251, T3.221 | 23.5d | 0d | SSH-Construction Manhours [400 h] | Z3 |
| T3.999 |  | Toilet 3 Finish | milestone | 0d | 2014-09-23 | 2014-09-23 | T3.261 | 23.5d | 0d |  | Z3 |
|  | 23 | **Snack Bar # 1** |  |  | 2014-02-01 | 2014-07-16 |  |  |  |  |  |
| SB1.121 |  | Surface preparation prior to painting |  | 20d | 2014-02-01 | 2014-02-18 | Eng.110 SS | 37.5d | 0d | SSH-Construction Manhours [600 h] | Z3 |
| SB1.131 |  | Underground piping works (water supply/Sewer) |  | 15d | 2014-02-19 | 2014-03-04 | SB1.121 | 37.5d | 0d | SSH-Construction Manhours [500 h] | Z3 |
| SB1.141 |  | Floor slab on grade |  | 21d | 2014-03-05 | 2014-03-24 | SB1.131 | 37.5d | 0d | SSH-Construction Manhours [600 h] | Z3 |
| SB1.151 |  | Roof water proofing works |  | 15d | 2014-03-19 | 2014-04-01 | SB1.141 SS+15d | 37.5d | 0d | SSH-Construction Manhours [500 h] | Z3 |
| SB1.161 |  | Ceiling works |  | 15d | 2014-04-02 | 2014-04-15 | SB1.151 | 37.5d | 0d | SSH-Construction Manhours [500 h] | Z3 |
| SB1.411 |  | Install electrical conduits |  | 30d | 2014-04-02 | 2014-04-29 | SB1.151 | 37.5d | 0d | SSH-Construction Manhours [500 h] | Z3 |
| SB1.511 |  | Install telecomm conduits |  | 30d | 2014-04-02 | 2014-04-29 | SB1.411 SS | 37.5d | 0d | SSH-Construction Manhours [500 h] | Z3 |
| SB1.111 |  | Backfilling |  | 30d | 2014-04-16 | 2014-05-13 | SB1.511 SS+15d, SB1.411 SS+15d | 37.5d | 0d | SSH-Construction Manhours [500 h] | Z3 |
| SB1.171 |  | Tiling works |  | 15d | 2014-04-16 | 2014-04-29 | SB1.161 | 37.5d | 0d | SSH-Construction Manhours [500 h] | Z3 |
| SB1.181 |  | Painting works |  | 15d | 2014-04-30 | 2014-05-13 | SB1.171 | 37.5d | 0d | SSH-Construction Manhours [500 h] | Z3 |
| SB1.421 |  | Install cables & wires |  | 15d | 2014-04-30 | 2014-05-13 | SB1.411, SB1.161 | 52.5d | 0d | SSH-Construction Manhours [500 h] | Z3 |
| SB1.521 |  | Install cabinet |  | 15d | 2014-04-30 | 2014-05-13 | SB1.421 SS, SB1.511 | 59.5d | 0d | SSH-Construction Manhours [400 h] | Z3 |
| SB1.191 |  | Plumbing fixtures |  | 15d | 2014-05-14 | 2014-05-27 | SB1.111, SB1.181 | 37.5d | 0d | SSH-Construction Manhours [200 h] | Z3 |
| SB1.431 |  | Install panel board |  | 15d | 2014-05-14 | 2014-05-27 | SB1.421 | 52.5d | 0d | SSH-Construction Manhours [200 h] | Z3 |
| SB1.531 |  | Install teleomm enclosure (incl:UTP cable, FOC, splice closure) |  | 15d | 2014-05-14 | 2014-05-27 | SB1.521 | 59.5d | 0d | SSH-Construction Manhours [400 h] | Z3 |
| SB1.201 |  | Doors & windows |  | 15d | 2014-05-28 | 2014-06-10 | SB1.191 | 37.5d | 0d | SSH-Construction Manhours [300 h] | Z3 |
| SB1.441 |  | Install lighting fixtures |  | 8d | 2014-05-28 | 2014-06-04 | SB1.431 | 52.5d | 0d | SSH-Construction Manhours [200 h] | Z3 |
| SB1.541 |  | Install CCTV camera system |  | 8d | 2014-05-28 | 2014-06-04 | SB1.531 | 59.5d | 0d | SSH-Construction Manhours [200 h] | Z3 |
| SB1.451 |  | Testing of electrical system |  | 15d | 2014-06-04 | 2014-06-18 | SB1.441 | 52.5d | 15d | SSH-Construction Manhours [400 h] | Z3 |
| SB1.551 |  | Install IPTV system |  | 8d | 2014-06-04 | 2014-06-11 | SB1.541 | 59.5d | 0d | SSH-Construction Manhours [200 h] | Z3 |
| SB1.211 |  | Install kitchen cabinet |  | 15d | 2014-06-11 | 2014-06-24 | SB1.201 | 37.5d | 0d | SSH-Construction Manhours [500 h] | Z3 |
| SB1.561 |  | Testing of telecomm system |  | 15d | 2014-06-11 | 2014-06-25 | SB1.551 | 59.5d | 22d | SSH-Construction Manhours [400 h] | Z3 |
| SB1.221 |  | Install kitchen & dinning equipments |  | 8d | 2014-06-25 | 2014-07-02 | SB1.211 | 37.5d | 0d | SSH-Construction Manhours [400 h] | Z3 |
| SB1.231 |  | Install wooden trellis |  | 15d | 2014-07-02 | 2014-07-16 | SB1.451, SB1.221 | 37.5d | 0d | SSH-Construction Manhours [400 h] | Z3 |
| SB1.999 |  | Snack Bar 1 Finish | milestone | 0d | 2014-07-16 | 2014-07-16 | SB1.231, SB2.999, SB1.561, SB1.111, SB1.451, SB3.999 | 37.5d | 14d |  | Z3 |

| ID | WBS | Activity | Type | Duration | Start | Finish | Predecessors | Total float | Free float | Resources | Department |
| --- | --- | --- | --- | --- | --- | --- | --- | --- | --- | --- | --- |
|  | 24 | **Snack Bar # 2** |  |  | 2014-02-01 | 2014-07-16 |  |  |  |  |  |
| SB2.121 |  | Surface preparation prior to painting |  | 30d | 2014-02-01 | 2014-02-27 | SB1.121 SS | 37.5d | 0d | SSH-Construction Manhours [600 h] | Z3 |
| SB2.111 |  | Backfilling |  | 30d | 2014-02-15 | 2014-03-13 | SB2.121 SS+15d | 42.5d | 5d | SSH-Construction Manhours [500 h] | Z3 |
| SB2.131 |  | Underground piping works (water supply/Sewer) |  | 15d | 2014-02-19 | 2014-03-04 | SB2.121 SS+20d | 37.5d | 0d | SSH-Construction Manhours [500 h] | Z3 |
| SB2.141 |  | Floor slab on grade |  | 21d | 2014-03-05 | 2014-03-24 | SB2.131 | 37.5d | 0d | SSH-Construction Manhours [600 h] | Z3 |
| SB2.151 |  | Roof water proofing works |  | 15d | 2014-03-19 | 2014-04-01 | SB2.141 SS+15d, SB2.111 | 37.5d | 0d | SSH-Construction Manhours [500 h] | Z3 |
| SB2.161 |  | Ceiling works |  | 15d | 2014-04-02 | 2014-04-15 | SB2.151 | 37.5d | 0d | SSH-Construction Manhours [500 h] | Z3 |
| SB2.411 |  | Install electrical conduits |  | 30d | 2014-04-02 | 2014-04-29 | SB2.151 | 52.5d | 0d | SSH-Construction Manhours [500 h] | Z3 |
| SB2.511 |  | Install telecomm conduits |  | 30d | 2014-04-02 | 2014-04-29 | SB2.411 SS | 59.5d | 0d | SSH-Construction Manhours [500 h] | Z3 |
| SB2.171 |  | Tiling works |  | 15d | 2014-04-16 | 2014-04-29 | SB2.161 | 37.5d | 0d | SSH-Construction Manhours [500 h] | Z3 |
| SB2.181 |  | Painting works |  | 15d | 2014-04-30 | 2014-05-13 | SB2.171 | 37.5d | 0d | SSH-Construction Manhours [500 h] | Z3 |
| SB2.421 |  | Install cables & wires |  | 15d | 2014-04-30 | 2014-05-13 | SB2.411, SB2.161 | 52.5d | 0d | SSH-Construction Manhours [500 h] | Z3 |
| SB2.521 |  | Install cabinet |  | 15d | 2014-04-30 | 2014-05-13 | SB2.511, SB2.421 SS | 59.5d | 0d | SSH-Construction Manhours [400 h] | Z3 |
| SB2.191 |  | Plumbing fixtures |  | 15d | 2014-05-14 | 2014-05-27 | SB2.181 | 37.5d | 0d | SSH-Construction Manhours [500 h] | Z3 |
| SB2.431 |  | Install panel board |  | 15d | 2014-05-14 | 2014-05-27 | SB2.421 | 52.5d | 0d | SSH-Construction Manhours [200 h] | Z3 |
| SB2.531 |  | Install teleomm enclosure (incl:UTP cable, FOC, splice closure) |  | 15d | 2014-05-14 | 2014-05-27 | SB2.521 | 59.5d | 0d | SSH-Construction Manhours [400 h] | Z3 |
| SB2.201 |  | Doors & windows |  | 15d | 2014-05-28 | 2014-06-10 | SB2.191 | 37.5d | 0d | SSH-Construction Manhours [200 h] | Z3 |
| SB2.441 |  | Install lighting fixtures |  | 8d | 2014-05-28 | 2014-06-04 | SB2.431 | 52.5d | 0d | SSH-Construction Manhours [200 h] | Z3 |
| SB2.541 |  | Install CCTV camera system |  | 8d | 2014-05-28 | 2014-06-04 | SB2.531 | 59.5d | 0d | SSH-Construction Manhours [200 h] | Z3 |
| SB2.451 |  | Testing of electrical system |  | 15d | 2014-06-04 | 2014-06-18 | SB2.441 | 52.5d | 15d | SSH-Construction Manhours [400 h] | Z3 |
| SB2.551 |  | Install IPTV system |  | 8d | 2014-06-04 | 2014-06-11 | SB2.541 | 59.5d | 0d | SSH-Construction Manhours [200 h] | Z3 |
| SB2.211 |  | Install kitchen cabinet |  | 15d | 2014-06-11 | 2014-06-24 | SB2.201 | 37.5d | 0d | SSH-Construction Manhours [300 h] | Z3 |
| SB2.561 |  | Testing of telecomm system |  | 15d | 2014-06-11 | 2014-06-25 | SB2.551 | 59.5d | 22d | SSH-Construction Manhours [400 h] | Z3 |
| SB2.221 |  | Install kitchen & dinning equipments |  | 8d | 2014-06-25 | 2014-07-02 | SB2.211 | 37.5d | 0d | SSH-Construction Manhours [400 h] | Z3 |
| SB2.231 |  | Install wooden trellis |  | 15d | 2014-07-02 | 2014-07-16 | SB2.221, SB2.451 | 37.5d | 0d | SSH-Construction Manhours [400 h] | Z3 |
| SB2.999 |  | Snack Bar 2 Finish | milestone | 0d | 2014-07-16 | 2014-07-16 | SB2.451, SB2.561, SB2.111, SB2.231 | 37.5d | 0d |  | Z3 |

| ID | WBS | Activity | Type | Duration | Start | Finish | Predecessors | Total float | Free float | Resources | Department |
| --- | --- | --- | --- | --- | --- | --- | --- | --- | --- | --- | --- |
|  | 25 | **Snack Bar # 3** |  |  | 2014-02-01 | 2014-07-16 |  |  |  |  |  |
| SB3.121 |  | Surface preparation prior to painting |  | 20d | 2014-02-01 | 2014-02-18 | SB2.121 SS | 37.5d | 0d | SSH-Construction Manhours [600 h] | Z3 |
| SB3.111 |  | Backfilling |  | 30d | 2014-02-15 | 2014-03-13 | SB3.121 SS+15d | 57.5d | 20d | SSH-Construction Manhours [500 h] | Z3 |
| SB3.131 |  | Underground piping works (water supply/Sewer) |  | 15d | 2014-02-19 | 2014-03-04 | SB3.121 | 37.5d | 0d | SSH-Construction Manhours [500 h] | Z3 |
| SB3.141 |  | Floor slab on grade |  | 21d | 2014-03-05 | 2014-03-24 | SB3.131, SB3.111 SS | 37.5d | 0d | SSH-Construction Manhours [600 h] | Z3 |
| SB3.151 |  | Roof water proofing works |  | 15d | 2014-03-19 | 2014-04-01 | SB3.141 SS+15d | 37.5d | 0d | SSH-Construction Manhours [500 h] | Z3 |
| SB3.161 |  | Ceiling works |  | 15d | 2014-04-02 | 2014-04-15 | SB3.151 | 37.5d | 0d | SSH-Construction Manhours [500 h] | Z3 |
| SB3.411 |  | Install electrical conduits |  | 30d | 2014-04-02 | 2014-04-29 | SB3.151 | 52.5d | 0d | SSH-Construction Manhours [500 h] | Z3 |
| SB3.511 |  | Install telecomm conduits |  | 30d | 2014-04-02 | 2014-04-29 | SB3.411 SS | 59.5d | 0d | SSH-Construction Manhours [500 h] | Z3 |
| SB3.171 |  | Tiling works |  | 15d | 2014-04-16 | 2014-04-29 | SB3.161 | 37.5d | 0d | SSH-Construction Manhours [500 h] | Z3 |
| SB3.181 |  | Painting works |  | 15d | 2014-04-30 | 2014-05-13 | SB3.171 | 37.5d | 0d | SSH-Construction Manhours [500 h] | Z3 |
| SB3.421 |  | Install cables & wires |  | 15d | 2014-04-30 | 2014-05-13 | SB3.411 | 52.5d | 0d | SSH-Construction Manhours [500 h] | Z3 |
| SB3.521 |  | Install cabinet |  | 15d | 2014-04-30 | 2014-05-13 | SB3.511 | 59.5d | 0d | SSH-Construction Manhours [400 h] | Z3 |
| SB3.191 |  | Plumbing fixtures |  | 15d | 2014-05-14 | 2014-05-27 | SB3.181 | 37.5d | 0d | SSH-Construction Manhours [500 h] | Z3 |
| SB3.431 |  | Install panel board |  | 15d | 2014-05-14 | 2014-05-27 | SB3.421 | 52.5d | 0d | SSH-Construction Manhours [200 h] | Z3 |
| SB3.531 |  | Install teleomm enclosure (incl:UTP cable, FOC, splice closure) |  | 15d | 2014-05-14 | 2014-05-27 | SB3.521 | 59.5d | 0d | SSH-Construction Manhours [400 h] | Z3 |
| SB3.201 |  | Doors & windows |  | 15d | 2014-05-28 | 2014-06-10 | SB3.191 | 37.5d | 0d | SSH-Construction Manhours [200 h] | Z3 |
| SB3.441 |  | Install lighting fixtures |  | 8d | 2014-05-28 | 2014-06-04 | SB3.431 | 52.5d | 0d | SSH-Construction Manhours [200 h] | Z3 |
| SB3.541 |  | Install CCTV camera system |  | 8d | 2014-05-28 | 2014-06-04 | SB3.531 | 59.5d | 0d | SSH-Construction Manhours [200 h] | Z3 |
| SB3.451 |  | Testing of electrical system |  | 15d | 2014-06-04 | 2014-06-18 | SB3.441 | 52.5d | 15d | SSH-Construction Manhours [400 h] | Z3 |
| SB3.551 |  | Install IPTV system |  | 8d | 2014-06-04 | 2014-06-11 | SB3.541 | 59.5d | 0d | SSH-Construction Manhours [200 h] | Z3 |
| SB3.211 |  | Install kitchen cabinet |  | 15d | 2014-06-11 | 2014-06-24 | SB3.201 | 37.5d | 0d | SSH-Construction Manhours [500 h] | Z3 |
| SB3.561 |  | Testing of telecomm system |  | 15d | 2014-06-11 | 2014-06-25 | SB3.551 | 59.5d | 22d | SSH-Construction Manhours [400 h] | Z3 |
| SB3.221 |  | Install kitchen & dinning equipments |  | 8d | 2014-06-25 | 2014-07-02 | SB3.211 | 37.5d | 0d | SSH-Construction Manhours [400 h] | Z3 |
| SB3.231 |  | Install wooden trellis |  | 15d | 2014-07-02 | 2014-07-16 | SB3.221, SB3.451 | 37.5d | 0d | SSH-Construction Manhours [400 h] | Z3 |
| SB3.999 |  | Snack Bar 3 Finish | milestone | 0d | 2014-07-16 | 2014-07-16 | SB4.999, SB3.231, SB3.111, SB3.561, SB3.451 | 37.5d | 0d |  | Z3 |

| ID | WBS | Activity | Type | Duration | Start | Finish | Predecessors | Total float | Free float | Resources | Department |
| --- | --- | --- | --- | --- | --- | --- | --- | --- | --- | --- | --- |
|  | 26 | **Snack Bar # 4** |  |  | 2014-02-01 | 2014-07-16 |  |  |  |  |  |
| SB4.121 |  | Surface preparation prior to painting |  | 30d | 2014-02-01 | 2014-02-27 | SB3.121 SS | 37.5d | 0d | SSH-Construction Manhours [600 h] | Z3 |
| SB4.111 |  | Backfilling |  | 30d | 2014-02-15 | 2014-03-13 | SB4.121 SS+15d | 42.5d | 5d | SSH-Construction Manhours [500 h] | Z3 |
| SB4.131 |  | Underground piping works (water supply/Sewer) |  | 15d | 2014-02-19 | 2014-03-04 | SB4.121 SS+20d | 37.5d | 0d | SSH-Construction Manhours [500 h] | Z3 |
| SB4.141 |  | Floor slab on grade |  | 21d | 2014-03-05 | 2014-03-24 | SB4.131 | 37.5d | 0d | SSH-Construction Manhours [600 h] | Z3 |
| SB4.151 |  | Roof water proofing works |  | 15d | 2014-03-19 | 2014-04-01 | SB4.111, SB4.141 SS+15d | 37.5d | 0d | SSH-Construction Manhours [500 h] | Z3 |
| SB4.161 |  | Ceiling works |  | 15d | 2014-04-02 | 2014-04-15 | SB4.151 | 37.5d | 0d | SSH-Construction Manhours [500 h] | Z3 |
| SB4.411 |  | Install electrical conduits |  | 30d | 2014-04-02 | 2014-04-29 | SB4.151 | 52.5d | 0d | SSH-Construction Manhours [500 h] | Z3 |
| SB4.511 |  | Install telecomm conduits |  | 30d | 2014-04-02 | 2014-04-29 | SB4.411 SS | 59.5d | 0d | SSH-Construction Manhours [500 h] | Z3 |
| SB4.171 |  | Tiling works |  | 15d | 2014-04-16 | 2014-04-29 | SB4.161 | 37.5d | 0d | SSH-Construction Manhours [500 h] | Z3 |
| SB4.181 |  | Painting works |  | 15d | 2014-04-30 | 2014-05-13 | SB4.171 | 37.5d | 0d | SSH-Construction Manhours [500 h] | Z3 |
| SB4.421 |  | Install cables & wires |  | 15d | 2014-04-30 | 2014-05-13 | SB4.411 | 52.5d | 0d | SSH-Construction Manhours [500 h] | Z3 |
| SB4.521 |  | Install cabinet |  | 15d | 2014-04-30 | 2014-05-13 | SB4.511 | 59.5d | 0d | SSH-Construction Manhours [400 h] | Z3 |
| SB4.191 |  | Plumbing fixtures |  | 15d | 2014-05-14 | 2014-05-27 | SB4.181 | 37.5d | 0d | SSH-Construction Manhours [500 h] | Z3 |
| SB4.431 |  | Install panel board |  | 15d | 2014-05-14 | 2014-05-27 | SB4.421 | 52.5d | 0d | SSH-Construction Manhours [200 h] | Z3 |
| SB4.531 |  | Install teleomm enclosure (incl:UTP cable, FOC, splice closure) |  | 15d | 2014-05-14 | 2014-05-27 | SB4.521 | 59.5d | 0d | SSH-Construction Manhours [400 h] | Z3 |
| SB4.201 |  | Doors & windows |  | 15d | 2014-05-28 | 2014-06-10 | SB4.191 | 37.5d | 0d | SSH-Construction Manhours [200 h] | Z3 |
| SB4.441 |  | Install lighting fixtures |  | 8d | 2014-05-28 | 2014-06-04 | SB4.431 | 52.5d | 0d | SSH-Construction Manhours [200 h] | Z3 |
| SB4.541 |  | Install CCTV camera system |  | 8d | 2014-05-28 | 2014-06-04 | SB4.531 | 59.5d | 0d | SSH-Construction Manhours [200 h] | Z3 |
| SB4.451 |  | Testing of electrical system |  | 15d | 2014-06-04 | 2014-06-18 | SB4.441 | 52.5d | 15d | SSH-Construction Manhours [400 h] | Z3 |
| SB4.551 |  | Install IPTV system |  | 8d | 2014-06-04 | 2014-06-11 | SB4.541 | 59.5d | 0d | SSH-Construction Manhours [200 h] | Z3 |
| SB4.211 |  | Install kitchen cabinet |  | 15d | 2014-06-11 | 2014-06-24 | SB4.201 | 37.5d | 0d | SSH-Construction Manhours [300 h] | Z3 |
| SB4.561 |  | Testing of telecomm system |  | 15d | 2014-06-11 | 2014-06-25 | SB4.551 | 59.5d | 22d | SSH-Construction Manhours [400 h] | Z3 |
| SB4.221 |  | Install kitchen & dinning equipments |  | 8d | 2014-06-25 | 2014-07-02 | SB4.211 | 37.5d | 0d | SSH-Construction Manhours [400 h] | Z3 |
| SB4.231 |  | Install wooden trellis |  | 15d | 2014-07-02 | 2014-07-16 | SB4.451, SB4.221 | 37.5d | 0d | SSH-Construction Manhours [400 h] | Z3 |
| SB4.999 |  | Snack Bar 4 Finish | milestone | 0d | 2014-07-16 | 2014-07-16 | SB4.231, SB4.111, SB4.451, SB4.561 | 37.5d | 0d |  | Z3 |

| ID | WBS | Activity | Type | Duration | Start | Finish | Predecessors | Total float | Free float | Resources | Department |
| --- | --- | --- | --- | --- | --- | --- | --- | --- | --- | --- | --- |
|  | 27 | **Picnic Shelters** |  |  | 2014-02-01 | 2014-04-10 |  |  |  |  |  |
| PR.S4.100 |  | Resolve Procurement & Engineering Issues |  | 15d | 2014-02-01 | 2014-02-13 | Eng.110 SS | 10.5d | 0d |  | Z3 |
| PR.S4.111 |  | Picnic shelters floor slab on grade Segment 4 |  | 60d | 2014-02-15 | 2014-04-10 | PR.S4.100 | 10.5d | 0d | SSH-Construction Manhours [750 h] | Z3 |
| PR.S4.131 |  | Wood trellis on picnic shelters Segment 4 |  | 60d | 2014-02-15 | 2014-04-10 | PR.S4.121 SS | 10.5d | 0d | SSH-Construction Manhours [750 h] | Z3 |
|  | 28 | **Fitness Shelters** |  |  | 2014-04-12 | 2014-06-05 |  |  |  |  |  |
| PR.S3.351 |  | Fitness shelters floor slab on grade Segment 3 |  | 30d | 2014-04-12 | 2014-05-08 | PR.S4.111 | 10.5d | 0d | SSH-Construction Manhours [1000 h] | Z3 |
| PR.S3.371 |  | Wood trellis on fitness shelters Segment 3 |  | 60d | 2014-04-12 | 2014-06-05 | PR.S3.351 SS, PR.S4.131 | 10.5d | 0d | SSH-Construction Manhours [1000 h] | Z3 |
|  | 29 | **Art Work Shelters** |  |  | 2014-05-10 | 2014-07-31 |  |  |  |  |  |
| PR.S2.551 |  | Artwork shelters floor slab on grade Segment 2 |  | 30d | 2014-05-10 | 2014-06-05 | PR.S3.351 | 15.5d | 0d | SSH-Construction Manhours [1000 h] | Z3 |
| PR.S2.571 |  | Wood trellis on artwork shelters Segment 2 |  | 60d | 2014-06-07 | 2014-07-31 | PR.S2.561 SS, PR.S3.371 | 25.5d | 10d | SSH-Construction Manhours [1000 h] | Z3 |
|  | 30 | **Pre-Commissioning Works** |  |  | 2014-07-14 | 2014-12-20 |  |  |  |  |  |
| PC.191 |  | Partial MCC & Punch List for Power Distrtibution |  | 30d | 2014-07-14 | 2014-08-10 | SS5.999, SS4.999, E.Works.999, Eng.200 SS | 20.5d | 20d | SSH-Construction Manhours [4600 h] | MGT |
| PC.131 |  | Partial MCC & Punch List for Irrigation water System |  | 30d | 2014-08-02 | 2014-08-28 | Eng.150 SS, IRR.999 | 120.5d | 121d | SSH-Construction Manhours [4600 h] | MGT |
| PC.111 |  | Partial MCC & Punch List for PW/FW System |  | 30d | 2014-08-20 | 2014-09-17 | PFW.999, Eng.130 SS | 99.5d | 100d | SSH-Construction Manhours [4600 h] | MGT |
| PC.121 |  | Partial MCC & Punch List for Sea-water System |  | 30d | 2014-08-25 | 2014-09-21 | Eng.140 SS, SW.999 | 95.5d | 96d | SSH-Construction Manhours [4600 h] | MGT |
| PC.171 |  | Partial MCC & Punch List for Road Network |  | 20d | 2014-11-03 | 2014-11-20 | Eng.180 SS, RD.999 | 30.5d | 31d | SSH-Construction Manhours [4600 h] | MGT |
| PC.141 |  | Partial MCC & Punch List for Sewer System |  | 30d | 2014-11-20 | 2014-12-18 | Eng.160 SS, GFL.999 | 1.5d | 2d | SSH-Construction Manhours [4600 h] | MGT |
| PC.151 |  | Partial MCC & Punch List for Lift Stations |  | 30d | 2014-11-20 | 2014-12-18 | LS12.999, LS9.999, LS10.999, LS11.999 | 1.5d | 2d | SSH-Construction Manhours [4600 h] | MGT |
| PC.181 |  | Partial MCC & Punch List for Public Realm |  | 30d | 2014-11-20 | 2014-12-18 | PR.Works.999, T2.999, T3.999, SB1.999, SB3.999, Eng.190 SS, T1.999, SB2.999, SB4.999 | 1.5d | 2d | SSH-Construction Manhours [4600 h] | MGT |
| PC.201 |  | Partial MCC & Punch List for Telecomm / Security System |  | 30d | 2014-11-22 | 2014-12-18 | AEB.999, TCOM.999, Eng.210 SS | 0.5d | 1d | SSH-Construction Manhours [4600 h] | MGT |
| PC.161 |  | Partial MCC & Punch List for Storm Drainage System |  | 20d | 2014-12-01 | 2014-12-20 | Eng.170 SS, SD.Works.999 | -0.5d | 0d | SSH-Construction Manhours [4600 h] | MGT |
| PC.999 |  | Pre-Commissioning Works Finish | milestone | 0d | 2014-12-20 | 2014-12-20 | PC.111, PC.191, Eng.140, PC.141, PC.151, Eng.160, Eng.190, Eng.200, PC.121, PC.181, Eng.170, Eng.210, PC.171, PC.201, Eng.150, Eng.180, Eng.130, PC.161, PC.131 | -0.5d | 0d |  | MGT |
|  | 31 | **Demobilization** |  |  | 2014-12-20 | 2014-12-31 |  |  |  |  |  |
| Dem.111 |  | Demobilization of Equipments & Manpower |  | 12d | 2014-12-20 | 2014-12-31 | SD.Works.999, PC.999, RD.999 | -0.5d | 0d | SSH-Construction Manhours [8500 h] | MGT |
| Dem.121 |  | Demobilization of Offices |  | 12d | 2014-12-20 | 2014-12-31 | Dem.111 SS | -0.5d | 0d | SSH-Construction Manhours [7500 h] | MGT |
| Dem.999 |  | Demobilization Finish | milestone | 0d | 2014-12-31 | 2014-12-31 | GFL.999, AEB.999, T1.999, E.Works.999, LS9.999, T2.999, PR.Works.999, LS11.999, PC.999, PFW.999, LS10.999, SS5.999, B.999, RD.999, SW.999, IRR.999, LS12.999, T3.999, SB2.999, SB3.999, TCOM.999, SB1.999, SB4.999, Dem.121, SS4.999, SD.Works.999 | -0.5d | 0d |  | MGT |

## Activity codes

| Code | Value | Meaning |
| --- | --- | --- |
| Department | ENG | Engineering Department |
| Department | MGT | Management |
| Department | Z1 | Zone 1 - KAUST - RPI |
| Department | Z2 | Zone 2 - KAUST - RPI |
| Department | Z3 | Zone 3 - KAUST - RPI |
| Department | Z4 | Zone 4 - KAUST - RPI |
