# KAUST-Research Park Infrastructure Project-04Oct2012

Schedule from Primavera P6, 2011-01-09 to 2014-01-04, data date 2012-10-04, costs in USD, A marks actual dates.
Recovery upto / 31May2012
Must finish by 2013-06-30

## Calendars

- SSH-Calendar: Mon-Thu 07:00-17:00; Fri off; Sat-Sun 07:00-17:00.

## Resources

| Resource | Group | Unit | Rate |
| --- | --- | --- | --- |
| SSH-Procurement Manhours | labor |  | 11 |
| SSH-Construction Manhours | labor |  | 58.05 |
| Truck Crane | material | ea | 164.88 |
| Trailer | equipment |  |  |
| Excavator | equipment |  |  |
| Dump Truck | equipment |  |  |
| Welding Machine | equipment |  |  |
| Cable Puller | equipment |  |  |
| Grader | equipment |  |  |
| Compactor | equipment |  |  |
| Asphalt Machine | equipment |  |  |
| Fork-Lifter | equipment |  |  |
| SSH-Design Manhours | labor |  | 11 |

## Schedule

| ID | WBS | Activity | Type | Duration | Start | Finish | Predecessors | Complete | Planned start | Planned finish | Total float | Free float | QTY |
| --- | --- | --- | --- | --- | --- | --- | --- | --- | --- | --- | --- | --- | --- |
|  | M | **MILESTONE DATES** |  |  | 2011-01-09 | 2014-01-04 |  |  |  |  |  |  |  |
|  | 1 | **Milestone Dates** |  |  | 2011-01-09 | 2014-01-04 |  |  |  |  |  |  |  |
| M1.00 |  | Notice to Proceed (NTP) | milestone | 0d | 2011-01-09 A | 2011-01-09 A |  | 100% | 2012-01-24 | 2012-01-24 |  |  |  |
| M1.01 |  | PMT & Contractor Design Office | milestone | 0d | 2011-01-19 A | 2011-01-19 A | 1.2.1.010 | 100% | 2012-01-24 | 2012-01-24 |  |  |  |
| M1.02 |  | Submit 120 Days Schedule | milestone | 0d | 2011-02-08 A | 2011-02-08 A | 1.2.2.010 | 100% | 2012-01-24 | 2012-01-24 |  |  |  |
| M1.03 |  | Complet Site Prep'n detailed design package | milestone | 0d | 2011-02-08 A | 2011-02-08 A | 1.4.1.1.210 | 100% | 2012-01-24 | 2012-01-24 |  |  |  |
| M2.03 |  | Compl't inst'n of jersey barrier & gates for zone 1 | milestone | 0d | 2011-02-20 A | 2011-02-20 A | 1.4.1.3.1.010 | 100% | 2012-01-24 | 2012-01-24 |  |  |  |
| M1.04 |  | Submit Project Execution Plan (PEP) | milestone | 0d | 2011-02-27 A | 2011-02-27 A | 1.2.3.010 | 100% | 2012-01-24 | 2012-01-24 |  |  |  |
| M2.02 |  | Compl't temporary construction site offices | milestone | 0d | 2011-03-20 A | 2011-03-20 A | 1.4.1.1.230, 1.4.1.1.120 | 100% | 2012-03-04 | 2012-03-04 |  |  |  |
| M1.05 |  | Submit Procurement Plan & Quality Plan | milestone | 0d | 2011-04-02 A | 2011-04-02 A | 1.2.3.015 | 100% | 2012-01-24 | 2012-01-24 |  |  |  |
| M1.08 |  | Complete 50% Engineering Design | milestone | 0d | 2011-06-04 A | 2011-06-04 A | 1.2.6.040 | 100% | 2012-01-24 | 2012-01-24 |  |  |  |
| M1.06 |  | Submit Work Schedule | milestone | 0d | 2011-07-04 A | 2011-07-04 A | 1.2.4.010 | 100% | 2012-01-24 | 2012-01-24 |  |  |  |
| M1.11 |  | Compl't 90% Engineering Design | milestone | 0d | 2011-07-04 A | 2011-07-04 A | 1.2.6.120 | 100% | 2012-01-24 | 2012-01-24 |  |  |  |
| M1.12 |  | Issue 100% IFC Drwaings | milestone | 0d | 2011-12-03 A | 2011-12-03 A | 1.2.6.200 | 100% | 2012-01-24 | 2012-01-24 |  |  |  |
| M2.01 |  | Compl't mobilization | milestone | 0d | 2012-01-15 A | 2012-01-15 A | 1.4.1.1.230 | 100% | 2012-01-24 | 2012-01-24 |  |  |  |
| M2.04 |  | Compl't inst'n of jersey barrier & gates for zone 3 | milestone | 0d | 2012-01-26 A | 2012-01-26 A | 1.4.1.3.3.010 | 100% | 2012-01-28 | 2012-01-28 |  |  |  |
| M2.05 |  | Compl't site prep & access road for zone 1 | milestone | 0d | 2012-03-27 A | 2012-03-27 A | Z1.1030 FF | 100% |  |  |  |  |  |
| M2.06 |  | Compl't inst'n of jersey barrier & gates for zone 4 | milestone | 0d | 2012-03-29 A | 2012-03-29 A | 1.4.1.3.4.010 | 100% |  |  |  |  |  |
| M2.07 |  | Compl't inst'n of jersey barrier & gates for zone 2 | milestone | 0d | 2012-03-29 A | 2012-03-29 A | 1.4.1.3.2.010 | 100% |  |  |  |  |  |
| M1.07 |  | Place PO for Long Lead Items | milestone | 0d | 2012-04-12 A | 2012-04-12 A | 1.2.5.010 | 100% |  |  |  |  |  |
| M1.10 |  | Compl't PO Placement of Bulk Items | milestone | 0d | 2012-04-12 A | 2012-04-12 A | 1.2.5.030 | 100% |  |  |  |  |  |
| M1.09 |  | Compl't PO Placement of Engineered Items | milestone | 0d | 2012-04-26 A | 2012-04-26 A | 1.2.5.020, 1.3.1.17.010 | 100% |  |  |  |  |  |
| M2.08 |  | Compl't site prep & access road for zone 3 | milestone | 0d | 2012-05-31 A | 2012-05-31 A | Z3.1020, Z3.2030, Z3.3020, Z3.4020, Z3.5020 | 100% |  |  |  |  |  |
| M2.09 |  | Compl't site prep & access roads for zone 2 & 4 | milestone | 0d | 2012-10-04 | 2012-10-04 | 1.4.1.3.2.010, 1.4.1.3.4.010 |  |  |  | 91.62d | 293.62d |  |
| M2.11 |  | Compl't Communications and Security Cabling | milestone | 0d | 2012-12-19 | 2012-12-19 | 1.4.2.8.1.090, 1.4.2.8.1.150, 1.4.2.8.1.150 FF, 1.4.2.8.1.130 |  |  |  | 10.5d | 212.5d |  |
| M2.19 |  | Compl't Spare Part Data Packages | milestone | 0d | 2013-01-24 | 2013-01-24 | 1.4.4.2.010, 1.4.4.1.030 |  |  |  | -28.25d | 173.75d |  |
| M2.10 |  | Energize Substation 4 and 5 | milestone | 0d | 2013-01-30 | 2013-01-30 | 1.4.3.1.1.570, 1.4.3.1.2.570, 1.4.2.7.1.070, 1.4.2.7.730 |  |  |  | -97.5d | 9.5d |  |
| M2.12 |  | Communications and Security Systems | milestone | 0d | 2013-03-04 | 2013-03-04 | 1.4.3.2.1.1110, 1.4.3.2.1.1210, 1.4.3.2.1.690, 1.4.3.2.1.1330 |  |  |  | -69.8d | 132.2d |  |
| M2.14 |  | Compl't Const'n & Energize the Comm'n Bld'g | milestone | 0d | 2013-03-05 | 2013-03-05 | 1.4.3.2.1.1340, 1.4.3.2.1.1520, 1.4.3.2.1.890 |  |  |  | -103d | 99.5d |  |
| M2.16 |  | Compl't Irrigation System | milestone | 0d | 2013-03-30 | 2013-03-30 | 1.3.4.14.020, 1.3.4.13.020, Z3.1330, Z3.2300, Z2.2290, Z3.1340, Z3.2310 |  |  |  | -96.69d | 105.31d |  |
| M2.13 |  | Compl't Power System | milestone | 0d | 2013-05-08 | 2013-05-08 | 1.4.2.7.4.045, 1.4.2.7.730, 1.4.2.7.4.075, 1.4.2.7.4.085 |  |  |  | -139.92d | 62.08d |  |
| M2.18 |  | Compl't Storm Drainage System | milestone | 0d | 2013-05-23 | 2013-05-23 | 1.4.2.4.2.050B, 1.4.2.4.2.090B, 1.4.2.4.2.040, 1.4.2.4.3.040, 1.4.2.4.1.015, 1.4.2.4.2.093C, 1.4.2.4.2.053C, 1.4.2.4.3.106C, 1.4.2.4.3.116C, 1.4.2.4.3.340, 1.4.2.4.4.120C, Z3.4060, Z3.5080, 1.4.2.4.2.054C, 1.4.2.4.3.070, 1.4.2.4.3.450, 1.4.2.4.3.530, 1.4.2.4.3.500, 1.4.2.4.3.720, 1.4.2.4.4.080 |  |  |  | -156.25d | 45.75d |  |
| M2.17 |  | Compl't Sanitary Sewer System | milestone | 0d | 2013-06-05 | 2013-06-05 | 1.4.2.3.5.140, 1.4.2.3.6.140, 1.4.2.3.7.140, 1.4.2.3.8.140, 1.4.2.3.7.150, 1.4.2.3.5.150, 1.4.2.3.8.150, 1.4.2.3.6.160, 1.4.2.3.7.160, 1.4.2.3.8.160, 1.4.2.3.5.160, Z3.3230, Z3.5050, Z3.2055, Z4.1180 |  |  |  | -202.5d | 0d |  |
| M2.15 |  | Compl't Potable and Fire Water Systems | milestone | 0d | 2013-06-17 | 2013-06-17 | Z3.2290, Z3.3270, Z2.1110, Z2.2310, Z4.1160, Z1.1060, Z2.1120, Z2.2320, Z4.1170, Z3.3280 |  |  |  | -182.5d | 19.5d |  |
| M2.21 |  | Mech'l Compl'n Certific'n of all works | milestone | 0d | 2013-07-03 | 2013-07-03 | 1.4.2.5.6.020A, 1.4.2.6.1.140, 1.4.3.3.1.3.120, 1.4.3.3.1.3.150, 1.4.3.3.1.3.180, 1.4.3.3.1.3.210, 1.4.3.3.1.3.300, 1.4.3.3.1.2.120, 1.4.3.5.1.140, 1.4.3.6.1.150, 1.4.3.4.4.170, 1.4.3.7.1.140, 1.4.3.7.1.100, 1.4.3.1.1.780, 1.4.3.1.1.820, 1.4.3.6.1.100, 1.4.3.3.1.2.210, 1.4.3.3.1.2.180, 1.4.3.3.1.2.300, 1.4.3.3.1.1.210, 1.4.3.3.1.1.120, 1.4.3.3.1.1.300, 1.4.2.7.4.075, 1.4.2.6.1.090, 1.4.2.5.6.020D, 1.4.2.5.3.110, 1.4.2.5.4.050, 1.4.2.7.2.090, 1.4.3.4.3.170, 1.4.2.7.2.092, 1.4.2.6.5.250, 1.4.2.6.4.250, 1.4.2.6.3.250, 1.4.2.6.2.250, 1.4.2.6.1.250, 1.4.2.6.5.260, 1.4.2.8.1.110, 1.4.4.3.010 |  |  |  | -200.42d | 2.08d |  |
| M2.20 |  | Compl't Redlined As-Built drawings | milestone | 0d | 2013-07-06 | 2013-07-06 | 1.4.4.5.040, 1.4.1.1.200 |  |  |  | -202d | 0d |  |
| M2.22 |  | Compl't all As-Built CAD work | milestone | 0d | 2013-08-05 | 2013-08-05 | 1.2.9.020, 1.4.4.6.020 |  |  |  | -202.5d | 0d |  |
| M2.23 |  | Scheduled Completion Date and Demobilization | milestone | 0d | 2014-01-04 | 2014-01-04 | 1.4.5.1.010, 1.4.5.1.020 |  |  |  | -202.5d | 0d | 0 |

| ID | WBS | Activity | Duration | Start | Finish | Predecessors | Complete | Planned start | Planned finish | Resources | Cost | QTY |
| --- | --- | --- | --- | --- | --- | --- | --- | --- | --- | --- | --- | --- |
|  | E | **DETAILED ENGINEERING / DESIGN** |  | 2011-01-09 | 2013-08-05 |  |  |  |  |  |  |  |
|  | 1 | **Categories 1** |  | 2011-01-09 | 2011-01-19 |  |  |  |  |  |  |  |
| 1.2.1.010 |  | PMT & Contractor Design office | 12d | 2011-01-09 A | 2011-01-19 A | M1.00 | 100% |  |  | SSH-Design Manhours [500 h] | 50,000 | 0.0147698364 |
|  | 2 | **Categories 2** |  | 2011-02-03 | 2011-04-02 |  |  |  |  |  |  |  |
| 1.2.2.010 |  | Submit 120 days schedule | 21d | 2011-02-03 A | 2011-02-08 A | 1.2.1.010, M1.01 | 100% | 2011-01-19 | 2011-02-08 | SSH-Design Manhours [400 h] | 40,000 |  |
| 1.2.2.020 |  | Submit drawing & document control index | 21d | 2011-03-03 A | 2011-04-02 A | 1.2.2.010 SS+15d | 100% | 2011-02-02 | 2011-02-22 | SSH-Design Manhours [300 h] | 30,000 | 0.0088619018 |
|  | 3 | **Categories 3** |  | 2011-02-15 | 2011-04-02 |  |  |  |  |  |  |  |
| 1.2.3.010 |  | Submit project execution plan PEP | 14d | 2011-02-15 A | 2011-02-27 A | 1.2.2.020 SS+8d, M1.02 | 100% | 2011-02-10 | 2011-02-23 | SSH-Design Manhours [250 h] | 25,000 |  |
| 1.2.3.015 |  | Submit Procurement plan & Quality Plan | 12d | 2011-03-22 A | 2011-04-02 A | 1.2.2.020 SS+10d, M1.03 | 100% | 2011-02-12 | 2011-02-23 | SSH-Design Manhours [250 h] |  | 0.0059079345 |
|  | 4 | **Categories 4** |  | 2011-03-02 | 2011-07-04 |  |  |  |  |  |  |  |
| 1.2.4.010 |  | Submit contractor deliverables & Work Schedule | 21.25d | 2011-03-02 A | 2011-07-04 A | 1.2.3.010 SS+10d | 100% | 2011-02-20 | 2011-03-10 | SSH-Design Manhours [600 h] | 60,000 | 0.0177238036 |
|  | 5 | **Categories 5** |  | 2011-08-13 | 2011-12-12 |  |  |  |  |  |  |  |
| 1.2.5.010 |  | Purchase orders placed for long lead items | 18.75d | 2011-08-13 A | 2011-08-29 A | 1.3.4.4.010 | 100% |  |  | SSH-Design Manhours [1800 h] | 180,000 |  |
| 1.2.5.020 |  | Purchase orders placed for all engineered items | 37.5d | 2011-09-17 A | 2011-10-20 A | 1.2.5.010 SS+12.5d | 100% |  |  | SSH-Design Manhours |  |  |
| 1.2.5.030 |  | Purchase orders placed for all bulk items | 56.25d | 2011-10-22 A | 2011-12-12 A | 1.3.1.1.010 SS, 1.2.5.020 SS | 100% |  |  | SSH-Design Manhours |  | 0.0177238036 |
|  | 6 | **Categories 6** |  | 2011-04-23 | 2011-12-03 |  |  |  |  |  |  |  |
| 1.2.6.010 |  | Preparation of 50% Civil drawings | 37.5d | 2011-04-23 A | 2011-06-04 A | 1.2.1.010 FS+8d | 100% | 2011-01-27 | 2011-03-02 | SSH-Design Manhours [6000 h] | 1,000,000 |  |
| 1.2.6.020 |  | Preparation of 50% Mechanical drawings | 37.5d | 2011-04-23 A | 2011-06-04 A | 1.2.6.010 SS+25d | 100% | 2011-02-20 | 2011-03-26 | SSH-Design Manhours [6000 h] | 1,500,000 |  |
| 1.2.6.030 |  | Preparation of 50% Electrical drawings | 37.5d | 2011-04-23 A | 2011-06-04 A | 1.2.6.020 SS+25d | 100% | 2011-03-15 | 2011-04-18 | SSH-Design Manhours [6000 h] | 1,500,000 |  |
| 1.2.6.040 |  | Preparation of 50% Communication drawings | 37.5d | 2011-04-23 A | 2011-06-04 A | 1.2.6.030 SS+22.5d | 100% | 2011-04-05 | 2011-05-09 | SSH-Design Manhours [6000 h] | 1,300,000 |  |
| 1.2.6.100 |  | Preparation of 90% Mechancial drawings | 25d | 2011-05-10 A | 2011-07-04 A | 1.2.6.090 SS+12.5d | 100% | 2011-05-22 | 2011-06-13 | SSH-Design Manhours [4000 h] | 750,000 |  |
| 1.2.6.110 |  | Preparation of 90% Electrical drawings | 25d | 2011-05-10 A | 2011-07-04 A | 1.2.6.100 SS+12.5d | 100% | 2011-06-02 | 2011-06-25 | SSH-Design Manhours [4000 h] | 750,000 |  |
| 1.2.6.120 |  | Preparation of 90% Communication drawings | 26.25d | 2011-05-10 A | 2011-07-04 A | 1.2.6.110 SS+12.5d | 100% | 2011-06-14 | 2011-07-07 | SSH-Design Manhours [4000 h] | 700,000 | 0.2067777089 |
| 1.2.6.090 |  | Preparation of 90% Civil drawings | 25d | 2011-05-10 A | 2011-07-04 A | 1.2.6.040, M1.04, M1.05, M1.06 | 100% | 2011-05-10 | 2011-06-01 | SSH-Design Manhours [4000 h] | 600,000 |  |
| 1.2.6.200 |  | Submit 100% IFC drawings | 32.5d | 2011-08-15 A | 2011-12-03 A | 1.2.6.120, 1.2.2.010, 1.2.2.020, 1.2.3.010, 1.2.3.015, 1.2.4.010, M1.08, M1.11 | 100% | 2011-07-09 | 2011-08-07 | SSH-Design Manhours [9829 h] | 75,000 |  |

| ID | WBS | Activity | Duration | Start | Finish | Predecessors | Complete | Planned start | Planned finish | Total float | Free float | Resources | Cost | QTY |
| --- | --- | --- | --- | --- | --- | --- | --- | --- | --- | --- | --- | --- | --- | --- |
|  | 7 | **Categories 7** |  | 2013-03-14 | 2013-04-10 |  |  |  |  |  |  |  |  |  |
| 1.2.7.010 |  | Submit Project Record books | 30d | 2013-03-14 | 2013-04-10 | 1.2.6.200 FS+100d, 1.2.5.030, 1.4.4.3.010 |  |  |  | -80.5d | 122d | SSH-Design Manhours [600 h] | 60,000 |  |
|  | 8 | **Categories 8** |  | 2012-10-04 | 2013-01-09 |  |  |  |  |  |  |  |  |  |
| 1.2.8.010 |  | Submit Pre-commissioning Plans | 75d | 2012-10-04 | 2012-12-12 | 1.2.6.200 FS+112.5d |  |  |  | -90d | 0d | SSH-Design Manhours [250 h] | 25,000 |  |
| 1.2.8.020 |  | Approved Pre-commissioning Plans | 75d | 2012-11-01 | 2013-01-09 | 1.2.8.010 FF+30d |  |  |  | -90d | 0d | SSH-Design Manhours [250 h] | 25,000 | 0.0073849182 |
|  | 9 | **Categories 9** |  | 2013-07-06 | 2013-08-05 |  |  |  |  |  |  |  |  |  |
| 1.2.9.020 |  | Complete Intergraph CADD | 33d | 2013-07-06 | 2013-08-05 | 1.2.9.010 FF |  |  |  | -202.5d | 0d | SSH-Design Manhours [500 h] | 100,000 |  |
| 1.2.9.010 |  | Complete As built Red lined drawings & CAD-work | 32.5d | 2013-07-06 | 2013-08-05 | 1.4.3.1.2.570, 1.4.4.5.040, 1.2.7.010 SS, M2.21 |  |  |  | -202.5d | 0d | SSH-Design Manhours [700 h] | 120,000 |  |
|  | P.1.3 | **PROCUREMENT** |  | 2011-01-12 | 2012-11-03 |  |  |  |  |  |  |  |  |  |
|  | 1 | **CIVIL / STRUCTURAL / ARCHITECTURAL / ROAD WORKS** |  | 2011-01-12 | 2012-11-03 |  |  |  |  |  |  |  |  |  |
|  | 01 | **FBE coated rebars** |  | 2011-07-10 | 2012-06-26 |  |  |  |  |  |  |  |  |  |
| 1.3.1.1.010 |  | Place PO for FBE coated rebars | 32.5d | 2011-07-10 A | 2011-07-31 A | 1.2.6.120 FS+12.5d | 100% | 2011-07-20 | 2011-08-18 |  |  | SSH-Procurement Manhours |  |  |
| 1.3.1.1.020 |  | Delivery of FBE coated rebars on site | 312.5d | 2011-09-10 A | 2012-06-26 A | 1.3.1.1.010 FS+22.5d | 100% |  |  |  |  | SSH-Procurement Manhours | 5,100,000 |  |
| 1.3.1.1.030 |  | Material receiving inspection & approval | 312.5d | 2011-09-10 A | 2012-06-26 A | 1.3.1.1.020 SS | 100% |  |  |  |  | SSH-Procurement Manhours |  | 0.3013046616 |
|  | 02 | **Structural Steel** |  | 2011-10-12 | 2012-01-22 |  |  |  |  |  |  |  |  |  |
| 1.3.1.2.010 |  | Place PO for structural stell | 37.5d | 2011-10-12 A | 2011-11-12 A | 1.3.1.1.010 SS+3d | 100% | 2011-07-23 | 2011-08-27 |  |  | SSH-Procurement Manhours |  |  |
| 1.3.1.2.020 |  | Delivery of structural steel on site | 5d | 2012-01-03 A | 2012-01-07 A | 1.3.1.2.010 FS+120d | 100% |  |  |  |  | SSH-Procurement Manhours | 1,800,000 |  |
| 1.3.1.2.030 |  | Material receiving inspection & approval | 6d | 2012-01-17 A | 2012-01-22 A | 1.3.1.2.020 | 100% |  |  |  |  | SSH-Procurement Manhours |  | 0.1358824944 |
|  | 03 | **Geogrid & Geotextile Materials** |  | 2011-10-10 | 2012-04-04 |  |  |  |  |  |  |  |  |  |
| 1.3.1.3.010 |  | Place PO for geogrid/geotextile materials | 37.5d | 2011-10-10 A | 2011-10-22 A | 1.3.1.2.010 SS+40d | 100% | 2011-08-29 | 2011-10-03 |  |  | SSH-Procurement Manhours |  |  |
| 1.3.1.3.020 |  | Delivery of geogrid/geotextile materials on site | 6d | 2012-03-25 A | 2012-03-31 A | 1.3.1.3.010 | 100% |  |  |  |  | SSH-Procurement Manhours | 1,020,000 |  |
| 1.3.1.3.030 |  | Material receiving inspection & approval | 6d | 2012-03-31 A | 2012-04-04 A | 1.3.1.3.020 SS | 100% |  |  |  |  | SSH-Procurement Manhours |  | 0.0602609323 |
|  | 04 | **Ceramic Tiles** |  | 2012-02-18 | 2012-05-07 |  |  |  |  |  |  |  |  |  |
| 1.3.1.4.010 |  | Place PO for ceramic tiles | 37.5d | 2012-02-18 A | 2012-03-22 A | 1.3.1.2.010 FS+5d | 100% |  |  |  |  | SSH-Procurement Manhours |  |  |
| 1.3.1.4.020 |  | Delivery of ceramic tiles on site | 5d | 2012-04-28 A | 2012-05-01 A | 1.3.1.4.010 FS+37.5d | 100% |  |  |  |  | SSH-Procurement Manhours | 1,186,000 |  |
| 1.3.1.4.030 |  | Material receiving inspection & approval | 6d | 2012-05-02 A | 2012-05-07 A | 1.3.1.4.020 | 100% |  |  |  |  | SSH-Procurement Manhours |  | 0.0759760382 |

| ID | WBS | Activity | Duration | Start | Finish | Predecessors | Complete | Planned start | Planned finish | Resources | Cost | QTY |
| --- | --- | --- | --- | --- | --- | --- | --- | --- | --- | --- | --- | --- |
|  | 05 | **CMU Blocks** |  | 2011-09-03 | 2012-01-09 |  |  |  |  |  |  |  |
| 1.3.1.5.010 |  | Place PO for CMU blocks | 37.5d | 2011-09-03 A | 2011-10-02 A | 1.3.1.3.010 | 100% | 2011-10-03 | 2011-11-07 | SSH-Procurement Manhours |  |  |
| 1.3.1.5.020 |  | Delivery of CMU blocks | 6d | 2011-12-29 A | 2012-01-04 A | 1.3.1.5.010 FS+56.25d | 100% |  |  | SSH-Procurement Manhours | 1,600,000 |  |
| 1.3.1.5.030 |  | Material receiving inspection & approval | 6d | 2012-01-04 A | 2012-01-09 A | 1.3.1.5.020 SS | 100% |  |  | SSH-Procurement Manhours |  | 0.1004348872 |
|  | 06 | **Concrete Tiles** |  | 2011-06-27 | 2012-04-11 |  |  |  |  |  |  |  |
| 1.3.1.6.010 |  | Place PO for concrete tiles | 37.5d | 2011-06-27 A | 2011-07-12 A | 1.3.1.3.010 SS+6.25d | 100% | 2011-09-04 | 2011-10-09 | SSH-Procurement Manhours |  |  |
| 1.3.1.6.020 |  | Delivery of concrete tiles | 5d | 2012-04-01 A | 2012-04-05 A | 1.3.1.6.010 FS+187.5d | 100% |  |  | SSH-Procurement Manhours | 1,794,000 |  |
| 1.3.1.6.030 |  | Material receiving inspection & approval | 6d | 2012-04-05 A | 2012-04-11 A | 1.3.1.6.020 SS | 100% |  |  | SSH-Procurement Manhours |  | 0.1059883457 |
|  | 07 | **Doors & Frames** |  | 2011-11-15 | 2012-06-03 |  |  |  |  |  |  |  |
| 1.3.1.7.010 |  | Place PO for doors & frames | 37.5d | 2011-11-15 A | 2012-01-10 A | 1.3.1.6.010 SS+12.5d | 100% | 2011-09-15 | 2011-10-20 | SSH-Procurement Manhours |  |  |
| 1.3.1.7.020 |  | Delivery of doors & frames on site | 5d | 2012-05-24 A | 2012-05-28 A | 1.3.1.7.010 FS+145d | 100% |  |  | SSH-Procurement Manhours | 508,500 |  |
| 1.3.1.7.030 |  | Material receiving inspection & approval | 6d | 2012-05-29 A | 2012-06-03 A | 1.3.1.7.020 | 100% |  |  | SSH-Procurement Manhours |  | 0.0300418471 |
|  | 08 | **Aluminium Windows** |  | 2012-02-18 | 2012-07-04 |  |  |  |  |  |  |  |
| 1.3.1.8.010 |  | Place PO for windows | 37.5d | 2012-02-18 A | 2012-03-22 A | 1.3.1.7.010 SS+2.5d | 100% |  |  | SSH-Procurement Manhours |  |  |
| 1.3.1.8.020 |  | Delivery of windows on site | 5d | 2012-06-25 A | 2012-06-28 A | 1.3.1.8.010 FS+100d | 100% |  |  | SSH-Procurement Manhours | 356,500 |  |
| 1.3.1.8.030 |  | Material receiving inspection & approval | 6d | 2012-06-30 A | 2012-07-04 A | 1.3.1.8.020 | 100% |  |  | SSH-Procurement Manhours |  | 0.003337983 |
|  | 09 | **Jersey Barriers** |  | 2011-02-14 | 2011-12-10 |  |  |  |  |  |  |  |
| 1.3.1.9.010 |  | Place PO for Jersey Barriers materials Materials | 7.5d | 2011-02-14 A | 2011-02-28 A | M1.00 FS+25d | 100% | 2011-02-01 | 2011-02-07 | SSH-Procurement Manhours |  |  |
| 1.3.1.9.020 |  | Fabrication & Delivery of materials for jersey bariers | 150d | 2011-03-09 A | 2011-12-10 A | 1.3.1.9.010 FS+11.25d | 100% | 2011-02-19 | 2011-07-07 | SSH-Procurement Manhours | 10,000,000 |  |
| 1.3.1.9.030 |  | Insp/Transporation of Jersey Barriers | 150d | 2011-03-09 A | 2011-12-10 A | 1.3.1.9.020 SS+10d | 100% | 2011-02-28 | 2011-07-17 | SSH-Procurement Manhours |  | 1.0929678901 |
|  | 10 | **Sliding & Swing Gates** |  | 2011-09-15 | 2011-11-21 |  |  |  |  |  |  |  |
| 1.3.1.10.010 |  | Place PO for sliding & swing gates | 7.5d | 2011-09-15 A | 2011-09-21 A | 1.3.1.9.010 FS+6.25d | 100% |  |  | SSH-Procurement Manhours |  |  |
| 1.3.1.10.020 |  | Delivery of sliding & swing gates | 5d | 2011-11-15 A | 2011-11-19 A | 1.3.1.10.010 FS+18.75d | 100% |  |  | SSH-Procurement Manhours | 85,000 |  |
| 1.3.1.10.030 |  | Material receiving inspection & approval | 3.75d | 2011-11-19 A | 2011-11-21 A | 1.3.1.10.020 | 100% |  |  | SSH-Procurement Manhours |  | 0.0050217444 |

| ID | WBS | Activity | Duration | Start | Finish | Predecessors | Complete | Remaining | Planned start | Planned finish | Total float | Free float | Resources | Cost | QTY |
| --- | --- | --- | --- | --- | --- | --- | --- | --- | --- | --- | --- | --- | --- | --- | --- |
|  | 11 | **Suspended Ceiling System** |  | 2011-11-19 | 2012-05-10 |  |  |  |  |  |  |  |  |  |  |
| 1.3.1.11.010 |  | Place PO for suspended ceiling system | 37.5d | 2011-11-19 A | 2011-12-22 A | 1.3.1.10.010 | 100% |  |  |  |  |  | SSH-Procurement Manhours |  |  |
| 1.3.1.11.020 |  | Delivery of suspended ceiling system | 6d | 2012-04-29 A | 2012-05-05 A | 1.3.1.11.010 FS+137d | 100% |  |  |  |  |  | SSH-Procurement Manhours | 900,000 |  |
| 1.3.1.11.030 |  | Material receiving inspection & approval | 6d | 2012-05-05 A | 2012-05-10 A | 1.3.1.11.020 | 100% |  |  |  |  |  | SSH-Procurement Manhours |  | 0.0590793454 |
|  | 12 | **Dry Wall Partition** |  | 2011-10-16 | 2012-05-09 |  |  |  |  |  |  |  |  |  |  |
| 1.3.1.12.010 |  | Place PO for dry wall partition | 37.5d | 2011-10-16 A | 2011-11-19 A | 1.3.1.11.010 SS | 100% |  |  |  |  |  | SSH-Procurement Manhours |  |  |
| 1.3.1.12.020 |  | Delivery of dry wall partition on site | 6d | 2012-04-29 A | 2012-05-05 A | 1.3.1.12.010 FS+173d | 100% |  |  |  |  |  | SSH-Procurement Manhours | 500,000 |  |
| 1.3.1.12.030 |  | Material receiving inspection & approval | 6d | 2012-05-05 A | 2012-05-09 A | 1.3.1.12.020 | 100% |  |  |  |  |  | SSH-Procurement Manhours |  | 0.0590793454 |
|  | 13 | **Pre-Cast Concrete Wall** |  | 2012-02-18 | 2012-05-29 |  |  |  |  |  |  |  |  |  |  |
| 1.3.1.13.010 |  | Place PO for precast concrete wall | 37.5d | 2012-02-18 A | 2012-03-22 A | 1.3.1.12.010 SS | 100% |  |  |  |  |  | SSH-Procurement Manhours |  |  |
| 1.3.1.13.020 |  | Delivery of precast concrete wall | 6d | 2012-05-19 A | 2012-05-23 A | 1.3.1.13.010 FS+60d | 100% |  |  |  |  |  | SSH-Procurement Manhours | 900,000 |  |
| 1.3.1.13.030 |  | Material receiving inspection & approval | 6d | 2012-05-23 A | 2012-05-29 A | 1.3.1.13.020 | 100% |  |  |  |  |  | SSH-Procurement Manhours |  | 0.0590793454 |
|  | 14 | **Concrete** |  | 2011-01-12 | 2012-11-03 |  |  |  |  |  |  |  |  |  |  |
| 1.3.1.14.010 |  | Place PO for Concrete | 6.25d | 2011-01-12 A | 2011-01-26 A | 1.3.1.9.010 SS | 100% |  | 2011-02-01 | 2011-02-06 |  |  | SSH-Procurement Manhours |  |  |
| 1.3.1.14.020 |  | Delivery of concrete on site | 650d | 2011-03-08 A | 2012-11-03 | 1.3.1.14.010 SS+37.5d | 95% | 32.5d |  |  | -182.5d | 0d | SSH-Procurement Manhours | 2,450,000 |  |
|  | 15 | **Aggregate, Crushed Stone & Backfilling Materials** |  | 2011-01-26 | 2011-09-25 |  |  |  |  |  |  |  |  |  |  |
| 1.3.1.15.010 |  | Place PO for Aggregate & Backfill materials | 37.5d | 2011-01-26 A | 2011-02-15 A | 1.3.1.14.010 FS+10d | 100% |  | 2011-02-16 | 2011-03-22 |  |  | SSH-Procurement Manhours |  |  |
| 1.3.1.15.020 |  | Delivery of Aggregate & Backfill materials | 187.5d | 2011-04-04 A | 2011-09-25 A | 1.3.1.15.010 FS+12.5d | 100% |  |  |  |  |  | SSH-Procurement Manhours | 4,500,000 |  |
|  | 16 | **Premix** |  | 2012-02-18 | 2012-10-04 |  |  |  |  |  |  |  |  |  |  |
| 1.3.1.16.010 |  | Place PO for Premix | 37.5d | 2012-02-18 A | 2012-03-22 A | 1.3.1.13.010 SS | 100% |  |  |  |  |  | SSH-Procurement Manhours |  |  |
| 1.3.1.16.020 |  | Delivery of Premix | 150d | 2012-05-19 A | 2012-10-04 | 1.3.1.16.010 FS+60d | 99% | 1.25d |  |  | -85.5d | 44.42d | SSH-Procurement Manhours | 500,000 |  |
|  | 17 | **Road Signange & Markings** |  | 2012-03-24 | 2012-09-13 |  |  |  |  |  |  |  |  |  |  |
| 1.3.1.17.010 |  | Place PO for road signage, markings | 37.5d | 2012-03-24 A | 2012-04-26 A | 1.3.1.16.010 | 100% |  |  |  |  |  | SSH-Procurement Manhours |  |  |
| 1.3.1.17.020 |  | Delivery of road signage , markings | 60d | 2012-07-21 A | 2012-09-13 A | 1.3.1.17.010 FS+90d | 100% |  |  |  |  |  | SSH-Procurement Manhours | 750,000 |  |

| ID | WBS | Activity | Duration | Start | Finish | Predecessors | Complete | Planned start | Planned finish | Resources | Cost | QTY |
| --- | --- | --- | --- | --- | --- | --- | --- | --- | --- | --- | --- | --- |
|  | 18 | **Ironmongery** |  | 2012-02-18 | 2012-05-31 |  |  |  |  |  |  |  |
| 1.3.1.18.010 |  | Place PO for Ironmongery | 37.5d | 2012-02-18 A | 2012-03-22 A | 1.3.1.16.010 SS | 100% |  |  | SSH-Procurement Manhours |  |  |
| 1.3.1.18.020 |  | Delivery of Ironmongery | 15d | 2012-05-19 A | 2012-05-31 A | 1.3.1.18.010 FS+60d | 100% |  |  | SSH-Procurement Manhours | 300,000 |  |
|  | 19 | **Paint** |  | 2011-12-04 | 2012-03-27 |  |  |  |  |  |  |  |
| 1.3.1.19.010 |  | Place PO for Paint | 37.5d | 2011-12-04 A | 2011-12-20 A | 1.3.1.15.020 SS | 100% | 2011-09-07 | 2011-10-11 | SSH-Procurement Manhours |  |  |
| 1.3.1.19.020 |  | Delivery of Paint | 6.25d | 2012-03-22 A | 2012-03-27 A | 1.3.1.19.010 FS+100d | 100% |  |  | SSH-Procurement Manhours | 250,000 |  |
|  | 20 | **Roofing Materials, membrane etc.** |  | 2011-11-15 | 2012-05-09 |  |  |  |  |  |  |  |
| 1.3.1.20.010 |  | Place PO for Roofing Materials & Membrane | 37.5d | 2011-11-15 A | 2011-12-19 A | 1.3.1.19.010 FF+12.5d | 100% |  |  | SSH-Procurement Manhours |  |  |
| 1.3.1.20.020 |  | Delivery of roofing Materials & Membrane | 2.5d | 2012-05-08 A | 2012-05-09 A | 1.3.1.20.010 FS+150d | 100% |  |  | SSH-Procurement Manhours | 300,000 |  |
|  | 21 | **Building Signage** |  | 2012-02-18 | 2012-06-28 |  |  |  |  |  |  |  |
| 1.3.1.21.010 |  | Place PO for Building Signage | 37.5d | 2012-02-18 A | 2012-03-22 A | 1.3.1.19.010 SS+37.5d | 100% |  |  | SSH-Procurement Manhours |  |  |
| 1.3.1.21.020 |  | Delivery of Buiding Signage | 5d | 2012-06-25 A | 2012-06-28 A | 1.3.1.21.010 FS+100d | 100% |  |  | SSH-Procurement Manhours | 300,000 |  |
|  | 22 | **Wood Terrlis** |  | 2012-03-24 | 2012-09-18 |  |  |  |  |  |  |  |
| 1.3.1.22.010 |  | Place PO for Wood Terrlis | 37.5d | 2012-03-24 A | 2012-04-26 A | 1.3.1.21.010 | 100% |  |  | SSH-Procurement Manhours |  |  |
| 1.3.1.22.020 |  | Delivery of Wood Terrlis | 5d | 2012-09-15 A | 2012-09-18 A | 1.3.1.22.010 FS+150d | 100% |  |  | SSH-Procurement Manhours | 250,000 |  |
|  | 23 | **Landscaping Materials** |  | 2012-02-18 | 2012-07-24 |  |  |  |  |  |  |  |
| 1.3.1.23.010 |  | Place PO for trees/shrubs/ground covers | 37.5d | 2012-02-18 A | 2012-03-22 A | 1.3.3.14.010 SS | 100% |  |  | SSH-Procurement Manhours |  |  |
| 1.3.1.23.020 |  | Delivery of trees/shrubs/ground covers | 6d | 2012-07-14 A | 2012-07-18 A | 1.3.1.23.010 FS+120d | 100% |  |  | SSH-Procurement Manhours | 2,950,000 |  |
| 1.3.1.23.030 |  | Material receiving inspection & approval | 6d | 2012-07-18 A | 2012-07-24 A | 1.3.1.23.020 | 100% |  |  | SSH-Procurement Manhours |  | 0.1181586908 |
|  | 24 | **Playground Materials** |  | 2012-03-24 | 2012-08-19 |  |  |  |  |  |  |  |
| 1.3.1.24.010 |  | Place PO for playground utilities | 37.5d | 2012-03-24 A | 2012-04-26 A | 1.3.1.23.010 | 100% |  |  | SSH-Procurement Manhours |  |  |
| 1.3.1.24.020 |  | Delivery of playground utilities | 6.25d | 2012-08-08 A | 2012-08-13 A | 1.3.1.24.010 FS+110d | 100% |  |  | SSH-Procurement Manhours | 1,100,000 |  |
| 1.3.1.24.030 |  | Provision of startup spare parts & Non-material-req'ts | 6d | 2012-08-14 A | 2012-08-19 A | 1.3.1.24.020 | 100% |  |  | SSH-Procurement Manhours |  | 0.1211126581 |
|  | 25 | **Fitness Shelter equipments & furniture** |  | 2012-03-28 | 2012-07-29 |  |  |  |  |  |  |  |
| 1.3.1.25.010 |  | Place PO for fitness & art shelters furniture | 37.5d | 2012-03-28 A | 2012-05-01 A | 1.3.1.24.010 SS+5d | 100% |  |  | SSH-Procurement Manhours |  |  |
| 1.3.1.25.020 |  | Delivery of fitness & art shelters furniture | 6d | 2012-07-18 A | 2012-07-23 A | 1.3.1.25.010 SS+120d | 100% |  |  | SSH-Procurement Manhours | 950,000 |  |
| 1.3.1.25.030 |  | SPDP/monthof fitness & art shelters furniture | 6d | 2012-07-23 A | 2012-07-29 A | 1.3.1.25.020 | 100% |  |  | SSH-Procurement Manhours |  | 0.0561253781 |

| ID | WBS | Activity | Duration | Start | Finish | Predecessors | Complete | Planned start | Planned finish | Resources | Cost | QTY |
| --- | --- | --- | --- | --- | --- | --- | --- | --- | --- | --- | --- | --- |
|  | 2 | **ELECTRICAL / INSTRUMENTATION WORKS** |  | 2011-03-12 | 2012-07-23 |  |  |  |  |  |  |  |
|  | 1 | **Switchgears** |  | 2011-05-26 | 2012-06-28 |  |  |  |  |  |  |  |
| 1.3.2.1.010 |  | Place PO for switchgears | 37.5d | 2011-05-26 A | 2011-06-26 A | 1.2.6.120 | 100% | 2011-07-09 | 2011-08-11 | SSH-Procurement Manhours | 605,100 |  |
| 1.3.2.1.020 |  | Delivery of switchgears | 6d | 2012-06-24 A | 2012-06-28 A | 1.3.2.1.010 FS+390d | 100% |  |  | SSH-Procurement Manhours | 4,235,700 |  |
| 1.3.2.1.030 |  | Provision of startup spare parts & Non-material-req'ts | 6d | 2012-06-24 A | 2012-06-28 A | 1.3.2.1.020 FF | 100% |  |  | SSH-Procurement Manhours | 1,210,200 | 0.5612537814 |
|  | 2 | **MCP -Motor Control Panel** |  | 2011-09-28 | 2012-06-02 |  |  |  |  |  |  |  |
| 1.3.2.2.010 |  | Place PO for Motor Control Panel | 37.5d | 2011-09-28 A | 2011-11-01 A | 1.3.2.1.010 SS+33.75d | 100% |  |  | SSH-Procurement Manhours | 403,400 |  |
| 1.3.2.2.020 |  | Delivery of MCP | 7.5d | 2012-05-21 A | 2012-05-27 A | 1.3.2.2.010 FS+215d | 100% |  |  | SSH-Procurement Manhours | 2,823,800 |  |
| 1.3.2.2.030 |  | Provision of startup spare parts & Non-material-req'ts | 6d | 2012-05-28 A | 2012-06-02 A | 1.3.2.2.020 | 100% |  |  | SSH-Procurement Manhours | 806,800 | 0.0345614171 |
|  | 3 | **Package Substations** |  | 2011-10-15 | 2012-06-24 |  |  |  |  |  |  |  |
| 1.3.2.3.010 |  | Place PO for package substations | 37.5d | 2011-10-15 A | 2011-11-15 A | 1.3.2.1.010 SS | 100% | 2011-07-09 | 2011-08-11 | SSH-Procurement Manhours | 265,000 |  |
| 1.3.2.3.020 |  | Delivery of package substations | 7.5d | 2012-06-12 A | 2012-06-18 A | 1.3.2.3.010 FS+225d | 100% |  |  | SSH-Procurement Manhours | 1,855,000 |  |
| 1.3.2.3.030 |  | Provision of startup spare parts & Non-material-req'ts | 6d | 2012-06-19 A | 2012-06-24 A | 1.3.2.3.020 | 100% |  |  | SSH-Procurement Manhours | 530,000 | 0.1565602653 |
|  | 4 | **RMU - Ring Main Units** |  | 2011-11-01 | 2012-06-20 |  |  |  |  |  |  |  |
| 1.3.2.4.010 |  | Place PO for RMU | 37.5d | 2011-11-01 A | 2011-11-15 A | 1.3.2.3.010 SS | 100% | 2011-07-09 | 2011-08-11 | SSH-Procurement Manhours | 2,040,000 |  |
| 1.3.2.4.020 |  | Delivery of RMU | 6d | 2012-06-10 A | 2012-06-16 A | 1.3.2.4.010 FS+223d | 100% |  |  | SSH-Procurement Manhours | 14,280,000 |  |
| 1.3.2.4.030 |  | Provision of startup spare parts & Non-material-req'ts | 6d | 2012-06-16 A | 2012-06-20 A | 1.3.2.4.020 | 100% |  |  | SSH-Procurement Manhours | 4,080,000 | 1.2052186464 |
|  | 5 | **Medium Voltage Cables** |  | 2011-06-20 | 2012-07-21 |  |  |  |  |  |  |  |
| 1.3.2.5.010 |  | Place PO for medium voltage cables | 37.5d | 2011-06-20 A | 2011-07-20 A | 1.3.2.4.010 SS | 100% | 2011-07-09 | 2011-08-11 | SSH-Procurement Manhours | 5,455,000 |  |
| 1.3.2.5.020 |  | Delivery of medium voltage cables | 250d | 2011-11-26 A | 2012-07-15 A | 1.3.2.5.010 FS+112.5d | 100% |  |  | SSH-Procurement Manhours | 38,185,000 |  |
| 1.3.2.5.030 |  | Provision of startup spare parts & Non-material-req'ts | 250d | 2011-12-01 A | 2012-07-21 A | 1.3.2.5.020 SS | 100% |  |  | SSH-Procurement Manhours | 10,910,000 | 3.2227782921 |
|  | 6 | **Diesel Generator** |  | 2011-08-15 | 2012-05-09 |  |  |  |  |  |  |  |
| 1.3.2.6.010 |  | Place PO for diesel generators | 37.5d | 2011-08-15 A | 2011-09-15 A | 1.3.4.4.010 SS | 100% | 2011-07-09 | 2011-08-11 | SSH-Procurement Manhours | 340,000 |  |
| 1.3.2.6.020 |  | Delivery of diesel generators | 6d | 2012-04-28 A | 2012-05-03 A | 1.3.2.6.010 FS+242d | 100% |  |  | SSH-Procurement Manhours | 2,380,000 |  |
| 1.3.2.6.030 |  | SPDP/monthof diesel generators | 6d | 2012-05-03 A | 2012-05-09 A | 1.3.2.6.020 | 100% |  |  | SSH-Procurement Manhours | 680,000 | 0.2008697744 |

| ID | WBS | Activity | Duration | Start | Finish | Predecessors | Complete | Planned start | Planned finish | Resources | Cost | QTY |
| --- | --- | --- | --- | --- | --- | --- | --- | --- | --- | --- | --- | --- |
|  | 7 | **Transformers** |  | 2011-10-13 | 2012-06-21 |  |  |  |  |  |  |  |
| 1.3.2.7.010 |  | Place PO for transformers | 37.5d | 2011-10-13 A | 2011-11-13 A | 1.3.2.6.010 SS | 100% | 2011-07-09 | 2011-08-11 | SSH-Procurement Manhours | 63,000 |  |
| 1.3.2.7.020 |  | Delivery of transformers | 6d | 2012-06-10 A | 2012-06-16 A | 1.3.2.7.010 FS+226d | 100% |  |  | SSH-Procurement Manhours | 441,000 |  |
| 1.3.2.7.030 |  | Provision of startup spare parts & Non-material-req'ts | 6d | 2012-06-16 A | 2012-06-21 A | 1.3.2.7.020 | 100% |  |  | SSH-Procurement Manhours | 126,000 | 0.0372199876 |
|  | 8 | **Circuit Breaker** |  | 2011-10-29 | 2012-07-04 |  |  |  |  |  |  |  |
| 1.3.2.8.010 |  | Place PO for circuit breaker | 37.5d | 2011-10-29 A | 2011-12-01 A | 1.3.2.7.010 FS+45d | 100% |  |  | SSH-Procurement Manhours |  |  |
| 1.3.2.8.020 |  | Delivery of circuit breaker | 6d | 2012-06-30 A | 2012-07-04 A | 1.3.2.8.010 FS+225d | 100% |  |  | SSH-Procurement Manhours | 630,000 |  |
| 1.3.2.8.030 |  | Provision of startup spare parts & Non-material-req'ts | 6d | 2012-06-30 A | 2012-07-04 A | 1.3.2.8.020 FF | 100% |  |  | SSH-Procurement Manhours |  | 0.0372199876 |
|  | 9 | **ATS - Automatic Transfer Switch** |  | 2011-10-15 | 2012-05-13 |  |  |  |  |  |  |  |
| 1.3.2.9.010 |  | Place PO for ATS | 37.5d | 2011-10-15 A | 2011-11-14 A | 1.3.2.7.010 SS | 100% | 2011-07-09 | 2011-08-11 | SSH-Procurement Manhours | 78,000 |  |
| 1.3.2.9.020 |  | Delivery of ATS | 6d | 2012-05-01 A | 2012-05-07 A | 1.3.2.9.010 FS+182d | 100% |  |  | SSH-Procurement Manhours | 546,000 |  |
| 1.3.2.9.030 |  | Provision of startup spare parts & Non-material-req'ts | 6d | 2012-05-07 A | 2012-05-13 A | 1.3.2.9.020 | 100% |  |  | SSH-Procurement Manhours | 156,000 | 0.0460818894 |
|  | 10 | **Switchboard** |  | 2011-11-01 | 2012-05-23 |  |  |  |  |  |  |  |
| 1.3.2.10.010 |  | Place PO for switchboards | 37.5d | 2011-11-01 A | 2011-11-20 A | 1.3.2.8.010 SS+37.5d | 100% | 2011-10-29 | 2011-12-01 | SSH-Procurement Manhours |  |  |
| 1.3.2.10.020 |  | Delivery of switchboards | 6d | 2012-05-13 A | 2012-05-17 A | 1.3.2.10.010 FS+187.5d | 100% |  |  | SSH-Procurement Manhours | 720,000 |  |
| 1.3.2.10.030 |  | Provision of startup spare parts & Non-material-req'ts | 6d | 2012-05-17 A | 2012-05-23 A | 1.3.2.10.020 | 100% |  |  | SSH-Procurement Manhours |  | 0.0425371287 |
|  | 11 | **Distribution Panel / Panel Boards** |  | 2011-10-18 | 2012-04-23 |  |  |  |  |  |  |  |
| 1.3.2.11.010 |  | Place PO for Distribution panel boards | 37.5d | 2011-10-18 A | 2011-11-21 A | 1.3.2.9.010 SS+31.25d | 100% |  |  | SSH-Procurement Manhours |  |  |
| 1.3.2.11.020 |  | Delivery of Distribution panel boards | 6d | 2012-04-12 A | 2012-04-18 A | 1.3.2.11.010 FS+153d | 100% |  |  | SSH-Procurement Manhours | 156,000 |  |
| 1.3.2.11.030 |  | Provision of startup spare parts & Non-material-req'ts | 6d | 2012-04-18 A | 2012-04-23 A | 1.3.2.11.020 | 100% |  |  | SSH-Procurement Manhours |  | 0.0092163779 |
|  | 12 | **Annunciator Panel** |  | 2011-10-12 | 2012-05-10 |  |  |  |  |  |  |  |
| 1.3.2.12.010 |  | Place PO for Annunciator panels | 37.5d | 2011-10-12 A | 2011-11-12 A | 1.3.2.11.010 SS+31.25d | 100% | 2011-09-05 | 2011-10-09 | SSH-Procurement Manhours |  |  |
| 1.3.2.12.020 |  | Delivery of Annunciator panels | 6d | 2012-04-29 A | 2012-05-05 A | 1.3.2.12.010 FS+182d | 100% |  |  | SSH-Procurement Manhours | 429,000 |  |
| 1.3.2.12.030 |  | Provision of startup spare parts & Non-material-req'ts | 6d | 2012-05-05 A | 2012-05-10 A | 1.3.2.12.020 | 100% |  |  | SSH-Procurement Manhours |  | 0.0253450392 |

| ID | WBS | Activity | Duration | Start | Finish | Predecessors | Complete | Planned start | Planned finish | Resources | Cost | QTY |
| --- | --- | --- | --- | --- | --- | --- | --- | --- | --- | --- | --- | --- |
|  | 13 | **Battery Bank, Battery Charger** |  | 2011-11-07 | 2012-07-22 |  |  |  |  |  |  |  |
| 1.3.2.13.010 |  | Place PO for Battery bank & charger | 37.5d | 2011-11-07 A | 2011-12-06 A | 1.3.2.12.010 SS+37.5d | 100% | 2011-10-10 | 2011-11-13 | SSH-Procurement Manhours |  |  |
| 1.3.2.13.020 |  | Delivery of Battery bank & charger | 6d | 2012-07-17 A | 2012-07-22 A | 1.3.2.13.010 FS+240d | 100% |  |  | SSH-Procurement Manhours | 237,500 |  |
| 1.3.2.13.030 |  | Provision of startup spare parts & Non-material-req'ts | 6d | 2012-07-17 A | 2012-07-22 A | 1.3.2.13.020 FF | 100% |  |  | SSH-Procurement Manhours |  | 0.0140313445 |
|  | 14 | **UPS System** |  | 2011-11-07 | 2012-07-23 |  |  |  |  |  |  |  |
| 1.3.2.14.010 |  | Place PO for UPS | 37.5d | 2011-11-07 A | 2011-12-06 A | 1.3.2.9.010 SS | 100% | 2011-07-09 | 2011-08-11 | SSH-Procurement Manhours | 20,000 |  |
| 1.3.2.14.020 |  | Delivery of UPS | 8.75d | 2012-07-15 A | 2012-07-23 A | 1.3.2.14.010 FS+238d | 100% |  |  | SSH-Procurement Manhours | 140,000 |  |
| 1.3.2.14.030 |  | Provision of startup spare parts & Non-material-req'ts | 6d | 2012-07-17 A | 2012-07-22 A | 1.3.2.14.020 SS+2d | 100% |  |  | SSH-Procurement Manhours | 40,000 | 0.0118158691 |
|  | 15 | **Electrical Grounding System** |  | 2011-11-30 | 2012-03-22 |  |  |  |  |  |  |  |
| 1.3.2.15.010 |  | Place PO for Electrical grounding system & Cables | 37.5d | 2011-11-30 A | 2011-12-12 A | 1.3.2.14.010 FS+18.75d | 100% | 2011-08-30 | 2011-10-03 | SSH-Procurement Manhours |  |  |
| 1.3.2.15.020 |  | Delivery of Electrical grounding system & Cables | 90d | 2011-12-31 A | 2012-03-22 A | 1.3.2.15.010 | 100% |  |  | SSH-Procurement Manhours | 150,000 |  |
| 1.3.2.15.030 |  | Provision of startup spare parts & Non-material-req'ts | 6d | 2012-01-04 A | 2012-01-10 A | 1.3.2.15.020 SS | 100% |  |  | SSH-Procurement Manhours |  | 0.0088619018 |
|  | 16 | **Electrical Conduits & Fittings** |  | 2011-11-21 | 2012-01-25 |  |  |  |  |  |  |  |
| 1.3.2.16.010 |  | Place PO for electrical conduits & fittings | 37.5d | 2011-11-21 A | 2011-12-28 A | 1.3.2.15.010 SS | 100% | 2011-08-30 | 2011-10-03 | SSH-Procurement Manhours |  |  |
| 1.3.2.16.020 |  | Delivery of electrical conduits & fittings | 60d | 2011-11-26 A | 2012-01-19 A | 1.3.2.16.010 | 100% |  |  | SSH-Procurement Manhours | 157,500 |  |
| 1.3.2.16.030 |  | Provision of startup spare parts & Non-material-req'ts | 60d | 2011-11-30 A | 2012-01-25 A | 1.3.2.16.020 SS | 100% |  |  | SSH-Procurement Manhours |  | 0.0093049969 |
|  | 17 | **Fire Detection System & FACP** |  | 2011-10-03 | 2012-05-19 |  |  |  |  |  |  |  |
| 1.3.2.17.010 |  | Place PO for fire detection sytem & FACP | 37.5d | 2011-10-03 A | 2011-11-03 A | 1.3.2.16.010 SS+37.5d | 100% | 2011-10-04 | 2011-11-07 | SSH-Procurement Manhours |  |  |
| 1.3.2.17.020 |  | Delivery of fire detection sytem & FACP | 6d | 2012-05-08 A | 2012-05-13 A | 1.3.2.17.010 FS+200d | 100% |  |  | SSH-Procurement Manhours | 590,000 |  |
| 1.3.2.17.030 |  | Provision of startup spare parts & Non-material-req'ts | 6d | 2012-05-13 A | 2012-05-19 A | 1.3.2.17.020 | 100% |  |  | SSH-Procurement Manhours |  | 0.0348568138 |
|  | 18 | **Electrical Ductbank Materials** |  | 2011-11-01 | 2011-12-28 |  |  |  |  |  |  |  |
| 1.3.2.18.020 |  | Delivery of electrical ductbank materials | 6d | 2011-11-01 A | 2011-11-06 A | 1.3.2.18.010 | 100% |  |  | SSH-Procurement Manhours |  |  |
| 1.3.2.18.030 |  | Material receiving inspection & approval | 6d | 2011-11-06 A | 2011-11-12 A | 1.3.2.18.020 FF | 100% |  |  | SSH-Procurement Manhours | 1,950,000 |  |
| 1.3.2.18.010 |  | Place PO for comm electrical ductbank materials | 37.5d | 2011-11-21 A | 2011-12-28 A | 1.3.3.13.010 SS | 100% | 2011-07-19 | 2011-08-22 |  |  |  |

| ID | WBS | Activity | Duration | Start | Finish | Predecessors | Complete | Planned start | Planned finish | Resources | Cost | QTY |
| --- | --- | --- | --- | --- | --- | --- | --- | --- | --- | --- | --- | --- |
|  | 19 | **Street Lighting Poles (For Patrol Roads)** |  | 2011-04-21 | 2011-12-18 |  |  |  |  |  |  |  |
| 1.3.2.19.010 |  | Place PO for street lighting poles (Patrol Roads) | 7.5d | 2011-04-21 A | 2011-05-21 A | 1.3.1.15.010 FS+100d | 100% | 2011-06-25 | 2011-06-30 | SSH-Procurement Manhours |  |  |
| 1.3.2.19.020 |  | Delivery of street lighting poles (Patrol Roads) | 6d | 2011-06-08 A | 2011-12-18 A | 1.3.2.19.010 FS+37.5d | 100% | 2011-08-06 | 2011-08-10 | SSH-Procurement Manhours | 1,903,200 |  |
| 1.3.2.19.030 |  | Provision of startup spare parts & Non-material-req'ts | 3.75d | 2011-06-08 A | 2011-12-18 A | 1.3.2.19.020 | 100% | 2011-08-10 | 2011-08-14 | SSH-Procurement Manhours |  | 0.3747993673 |
|  | 20 | **Street Light Poles (For Permanent Roads)** |  | 2011-10-13 | 2012-05-05 |  |  |  |  |  |  |  |
| 1.3.2.20.010 |  | Place PO for Light Poles (Permanent Roads) | 30d | 2011-10-13 A | 2011-11-09 A | 1.3.2.24.010 SS+10d | 100% |  |  | SSH-Procurement Manhours |  |  |
| 1.3.2.20.020 |  | Delivery of Light Poles (Permenent Roads) | 7.5d | 2012-04-22 A | 2012-04-28 A | 1.3.2.20.010 FS+175d | 100% |  |  | SSH-Procurement Manhours | 4,440,800 |  |
| 1.3.2.20.030 |  | Provision of startup spare parts & Non-material-req'ts | 7.5d | 2012-04-29 A | 2012-05-05 A | 1.3.2.20.020 | 100% |  |  | SSH-Procurement Manhours |  |  |
|  | 21 | **Street Lighting Fixtures (For Patrol Roads)** |  | 2011-03-12 | 2011-09-17 |  |  |  |  |  |  |  |
| 1.3.2.21.010 |  | Place PO for street lighting fixtures (Patrol Roads) | 7.5d | 2011-03-12 A | 2011-04-12 A | 1.3.2.19.010 SS | 100% | 2011-06-25 | 2011-06-30 | SSH-Procurement Manhours |  |  |
| 1.3.2.21.020 |  | Delivery of street lighting fixtures (Patrol Roads) | 5d | 2011-08-13 A | 2011-09-17 A | 1.3.2.21.010 FS+37.5d | 100% | 2011-08-06 | 2011-08-09 | SSH-Procurement Manhours | 658,800 |  |
| 1.3.2.21.030 |  | Provision of startup spare parts & Non-material-req'ts | 3.75d | 2011-08-13 A | 2011-09-17 A | 1.3.2.21.020 | 100% | 2011-08-10 | 2011-08-13 | SSH-Procurement Manhours |  | 0.1297382425 |
|  | 22 | **Street Light Fixtures (For Permenent Roads)** |  | 2011-10-13 | 2012-05-07 |  |  |  |  |  |  |  |
| 1.3.2.22.010 |  | Place PO for Light Fixtures (Permanent Roads) | 37.5d | 2011-10-13 A | 2011-11-16 A | 1.3.2.20.010 SS | 100% |  |  | SSH-Procurement Manhours |  |  |
| 1.3.2.22.020 |  | Delivery of Light Fixtures (Permanent Roads) | 7.5d | 2012-04-24 A | 2012-04-30 A | 1.3.2.22.010 FS+170d | 100% |  |  | SSH-Procurement Manhours | 1,537,200 |  |
| 1.3.2.22.030 |  | Provision of startup spare parts & Non-material-req'ts | 7.5d | 2012-05-01 A | 2012-05-07 A | 1.3.2.22.020 | 100% |  |  | SSH-Procurement Manhours |  |  |
|  | 23 | **LV Cables (For Patrol Roads)** |  | 2011-08-03 | 2011-09-04 |  |  |  |  |  |  |  |
| 1.3.2.23.020 |  | Delivery of LV cables (Patrol Roads) | 5d | 2011-08-03 A | 2011-08-07 A | 1.3.2.23.010 FS+37.5d | 100% |  |  | SSH-Procurement Manhours | 1,917,858 |  |
| 1.3.2.23.010 |  | Place PO for LV cables (Patrol Roads) | 5d | 2011-08-04 A | 2011-09-04 A | 1.3.2.21.010 SS | 100% | 2011-06-25 | 2011-06-28 | SSH-Procurement Manhours |  |  |
| 1.3.2.23.030 |  | Provision of startup spare parts & Non-material-req'ts | 3.75d | 2011-08-08 A | 2011-08-10 A | 1.3.2.23.020 SS | 100% |  |  | SSH-Procurement Manhours |  | 0.3776859841 |
|  | 24 | **LV Cables (For Permanent Roads)** |  | 2011-10-01 | 2012-04-11 |  |  |  |  |  |  |  |
| 1.3.2.24.010 |  | Place PO for LV cables (Permanent Roads) | 30d | 2011-10-01 A | 2011-11-16 A | 1.3.2.23.010 SS | 100% | 2011-10-20 | 2011-11-16 | SSH-Procurement Manhours |  |  |
| 1.3.2.24.020 |  | Delivery of LV Cables (Permanent Roads) | 7.5d | 2012-04-05 A | 2012-04-11 A | 1.3.2.24.010 FS+150d | 100% |  |  | SSH-Procurement Manhours | 4,475,002 |  |
| 1.3.2.24.030 |  | Provision of startup spare parts & Non-material-req'ts | 7.5d | 2012-04-05 A | 2012-04-11 A | 1.3.2.24.020 SS | 100% |  |  | SSH-Procurement Manhours |  |  |

| ID | WBS | Activity | Duration | Start | Finish | Predecessors | Complete | Planned start | Planned finish | Resources | Cost | QTY |
| --- | --- | --- | --- | --- | --- | --- | --- | --- | --- | --- | --- | --- |
|  | 25 | **Volume & Fire Dampers** |  | 2012-02-18 | 2012-05-29 |  |  |  |  |  |  |  |
| 1.3.2.25.010 |  | Place PO for volume & fire dampers | 30d | 2012-02-18 A | 2012-03-15 A | 1.3.4.15.010 SS+12.5d | 100% |  |  | SSH-Procurement Manhours |  |  |
| 1.3.2.25.020 |  | Delivery of volume & fire dampers | 10d | 2012-05-12 A | 2012-05-20 A | 1.3.2.25.010 FS+60d | 100% |  |  | SSH-Procurement Manhours | 312,500 |  |
| 1.3.2.25.030 |  | Provision of startup spare parts & Non-material-req'ts | 10d | 2012-05-21 A | 2012-05-29 A | 1.3.2.25.020 | 100% |  |  | SSH-Procurement Manhours |  | 0.0184622954 |
|  | 26 | **Moduler Rectifier / Inverter** |  | 2011-09-28 | 2012-07-02 |  |  |  |  |  |  |  |
| 1.3.2.26.010 |  | Place PO for moduler rectifier / inverter | 30d | 2011-09-28 A | 2011-10-25 A | 1.3.2.23.010 SS | 100% |  |  | SSH-Procurement Manhours |  |  |
| 1.3.2.26.020 |  | Delivery of moduler rectifier / inverter | 6d | 2012-06-25 A | 2012-06-30 A | 1.3.2.26.010 FS+260d | 100% |  |  | SSH-Procurement Manhours | 212,500 |  |
| 1.3.2.26.030 |  | Provision of startup spare parts & Non-material-req'ts | 6d | 2012-06-26 A | 2012-07-02 A | 1.3.2.26.020 FF+2d | 100% |  |  | SSH-Procurement Manhours |  | 0.0125543609 |
|  | 3 | **SECURITY / COMMUNICATION WORKS** |  | 2011-09-28 | 2012-07-29 |  |  |  |  |  |  |  |
|  | 1 | **Fiber Optic Cables** |  | 2011-12-01 | 2012-05-03 |  |  |  |  |  |  |  |
| 1.3.3.1.010 |  | Place PO for fiber optic cables | 37.5d | 2011-12-01 A | 2011-12-17 A | 1.2.6.040 FS+10d, 1.3.2.12.010 SS+10d | 100% | 2011-09-14 | 2011-10-18 | SSH-Procurement Manhours |  |  |
| 1.3.3.1.020 |  | Delivery of fiber optic cables | 6d | 2012-04-22 A | 2012-04-28 A | 1.3.3.1.010 FS+137d | 100% |  |  | SSH-Procurement Manhours | 4,363,000 |  |
| 1.3.3.1.030 |  | Provision of startup spare parts & Non-material-req'ts | 6d | 2012-04-28 A | 2012-05-03 A | 1.3.3.1.020 | 100% |  |  | SSH-Procurement Manhours |  | 0.0268811022 |
|  | 2 | **Patch Panels** |  | 2012-02-18 | 2012-07-29 |  |  |  |  |  |  |  |
| 1.3.3.2.010 |  | Place PO for fiber optic patch panels | 37.5d | 2012-02-18 A | 2012-03-22 A | 1.3.3.1.010 SS+37.5d | 100% |  |  | SSH-Procurement Manhours |  |  |
| 1.3.3.2.020 |  | Delivery of fiber optic patch panels | 6d | 2012-07-18 A | 2012-07-23 A | 1.3.3.2.010 FS+125d | 100% |  |  | SSH-Procurement Manhours | 220,000 |  |
| 1.3.3.2.030 |  | Provision of startup spare parts & Non-material-req'ts | 6d | 2012-07-23 A | 2012-07-29 A | 1.3.3.2.020 | 100% |  |  | SSH-Procurement Manhours |  | 0.0070895214 |
|  | 3 | **Splice Enclosure** |  | 2012-03-12 | 2012-07-23 |  |  |  |  |  |  |  |
| 1.3.3.3.010 |  | Place PO for fiber optic splice closure | 37.5d | 2012-03-12 A | 2012-04-15 A | 1.3.3.2.010 SS+25d | 100% |  |  | SSH-Procurement Manhours |  |  |
| 1.3.3.3.020 |  | Delivery of fiber optic splice closure | 6d | 2012-07-18 A | 2012-07-23 A | 1.3.3.3.010 FS+100d | 100% |  |  | SSH-Procurement Manhours | 275,000 |  |
| 1.3.3.3.030 |  | Provision of startup spare parts & Non-material-req'ts | 6d | 2012-07-18 A | 2012-07-23 A | 1.3.3.3.020 FF | 100% |  |  | SSH-Procurement Manhours |  | 0.01624682 |
|  | 4 | **Copper Cables** |  | 2011-11-20 | 2012-07-02 |  |  |  |  |  |  |  |
| 1.3.3.4.010 |  | Place PO for copper cables | 37.5d | 2011-11-20 A | 2011-12-24 A | 1.3.2.26.010 SS | 100% |  |  | SSH-Procurement Manhours |  |  |
| 1.3.3.4.020 |  | Delivery of copper cables | 6d | 2012-06-21 A | 2012-06-27 A | 1.3.3.4.010 FS+193d | 100% |  |  | SSH-Procurement Manhours | 4,642,000 |  |
| 1.3.3.4.030 |  | Provision of startup spare parts & Non-material-req'ts | 6d | 2012-06-27 A | 2012-07-02 A | 1.3.3.4.020 | 100% |  |  | SSH-Procurement Manhours |  | 0.5110363378 |

| ID | WBS | Activity | Duration | Start | Finish | Predecessors | Complete | Planned start | Planned finish | Resources | Cost | QTY |
| --- | --- | --- | --- | --- | --- | --- | --- | --- | --- | --- | --- | --- |
|  | 5 | **Comm Duct & Sub-duct Conduits & Fittings** |  | 2011-12-05 | 2012-01-15 |  |  |  |  |  |  |  |
| 1.3.3.5.010 |  | Place PO for comm duct & subduct conduits & fittings | 37.5d | 2011-12-05 A | 2011-12-28 A | 1.3.2.14.010 SS+5d | 100% | 2011-07-13 | 2011-08-16 | SSH-Procurement Manhours |  |  |
| 1.3.3.5.020 |  | Delivery of comm duct & subduct conduits & fittings | 6d | 2012-01-04 A | 2012-01-09 A | 1.3.3.5.010 | 100% |  |  | SSH-Procurement Manhours | 525,000 |  |
| 1.3.3.5.030 |  | Provision of startup spare parts & Non-material-req'ts | 6d | 2012-01-09 A | 2012-01-15 A | 1.3.3.5.020 SS | 100% |  |  | SSH-Procurement Manhours |  | 0.0310166563 |
|  | 6 | **Communication Cabinet & Accs** |  | 2012-02-18 | 2012-05-29 |  |  |  |  |  |  |  |
| 1.3.3.6.010 |  | Place PO for comm cabinet & accs | 37.5d | 2012-02-18 A | 2012-03-22 A | 1.3.3.5.010 SS+18.75d | 100% |  |  | SSH-Procurement Manhours |  |  |
| 1.3.3.6.020 |  | Delivery of comm cabinet & accs | 6d | 2012-05-19 A | 2012-05-23 A | 1.3.3.6.010 FS+60d | 100% |  |  | SSH-Procurement Manhours | 500,000 |  |
| 1.3.3.6.030 |  | Provision of startup spare parts & Non-material-req'ts | 6d | 2012-05-23 A | 2012-05-29 A | 1.3.3.6.020 | 100% |  |  | SSH-Procurement Manhours |  | 0.0295396727 |
|  | 7 | **Comm Cable Trays** |  | 2011-09-28 | 2012-03-13 |  |  |  |  |  |  |  |
| 1.3.3.7.010 |  | Place PO for cable trays | 25d | 2011-09-28 A | 2011-10-20 A | 1.3.2.14.010 SS+31.25d | 100% |  |  | SSH-Procurement Manhours |  |  |
| 1.3.3.7.020 |  | Delivery of cabel trays | 6d | 2012-03-03 A | 2012-03-08 A | 1.3.3.7.010 FS+143d | 100% |  |  | SSH-Procurement Manhours | 600,000 |  |
| 1.3.3.7.030 |  | Material receiving inspection & approval | 6d | 2012-03-08 A | 2012-03-13 A | 1.3.3.7.020 | 100% |  |  | SSH-Procurement Manhours |  | 0.0354476072 |
|  | 8 | **Telecomm Equipments** |  | 2011-12-19 | 2012-05-13 |  |  |  |  |  |  |  |
| 1.3.3.8.010 |  | Place PO for Telecfomm equipments | 37.5d | 2011-12-19 A | 2012-01-11 A | 1.3.3.7.010 SS | 100% | 2011-08-30 | 2011-10-03 | SSH-Procurement Manhours |  |  |
| 1.3.3.8.020 |  | Delivery of telecomm equipments | 6d | 2012-05-02 A | 2012-05-07 A | 1.3.3.8.010 FS+120d | 100% |  |  | SSH-Procurement Manhours | 700,000 |  |
| 1.3.3.8.030 |  | Material receiving inspection & approval | 6d | 2012-05-07 A | 2012-05-13 A | 1.3.3.8.020 | 100% |  |  | SSH-Procurement Manhours |  | 0.0413555418 |
|  | 9 | **Comm Copper Cable Closure** |  | 2012-02-18 | 2012-05-20 |  |  |  |  |  |  |  |
| 1.3.3.9.010 |  | Place PO for comm copper cable closure | 27.5d | 2012-02-18 A | 2012-03-13 A | 1.3.3.8.010 SS | 100% |  |  | SSH-Procurement Manhours |  |  |
| 1.3.3.9.020 |  | Delivery of comm copper cable closure | 6d | 2012-05-09 A | 2012-05-14 A | 1.3.3.9.010 FS+60d | 100% |  |  | SSH-Procurement Manhours | 160,000 |  |
| 1.3.3.9.030 |  | Provision of startup spare parts & Non-material-req'ts | 6d | 2012-05-14 A | 2012-05-20 A | 1.3.3.9.020 | 100% |  |  | SSH-Procurement Manhours |  | 0.0094526953 |
|  | 10 | **Comm Grounding System** |  | 2011-12-06 | 2012-03-26 |  |  |  |  |  |  |  |
| 1.3.3.10.010 |  | Place PO for comm grounding system | 37.5d | 2011-12-06 A | 2012-01-09 A | 1.3.3.7.010 | 100% |  |  | SSH-Procurement Manhours |  |  |
| 1.3.3.10.020 |  | Delivery of comm grounding system | 6d | 2012-03-15 A | 2012-03-20 A | 1.3.3.10.010 FS+70d | 100% |  |  | SSH-Procurement Manhours | 52,500 |  |
| 1.3.3.10.030 |  | Provision of startup spare parts & Non-material-req'ts | 6d | 2012-03-20 A | 2012-03-26 A | 1.3.3.10.020 | 100% |  |  | SSH-Procurement Manhours |  | 0.0031016656 |

| ID | WBS | Activity | Duration | Start | Finish | Predecessors | Complete | Planned start | Planned finish | Resources | Cost | QTY |
| --- | --- | --- | --- | --- | --- | --- | --- | --- | --- | --- | --- | --- |
|  | 11 | **Comm FOC [Fiber Optic Cable] Manholes** |  | 2012-02-18 | 2012-05-29 |  |  |  |  |  |  |  |
| 1.3.3.11.010 |  | Place PO for FOC Manholes | 37.5d | 2012-02-18 A | 2012-03-22 A | 1.3.2.14.010 SS+5d | 100% |  |  |  |  |  |
| 1.3.3.11.020 |  | Delivery of comm manhole materials | 6.25d | 2012-05-19 A | 2012-05-23 A | 1.3.3.11.010 FS+60d | 100% |  |  | SSH-Procurement Manhours |  |  |
| 1.3.3.11.030 |  | Material receiving inspection & approval | 6d | 2012-05-24 A | 2012-05-29 A | 1.3.3.11.020 | 100% |  |  | SSH-Procurement Manhours | 1,010,000 |  |
|  | 12 | **Comm Copper Cable Manholes** |  | 2012-02-18 | 2012-05-29 |  |  |  |  |  |  |  |
| 1.3.3.12.010 |  | Place PO for Copper cable Manholes | 37.5d | 2012-02-18 A | 2012-03-22 A | 1.3.3.11.010 SS | 100% |  |  |  |  |  |
| 1.3.3.12.020 |  | Delivery of comm copper cable manhole materials | 6d | 2012-05-19 A | 2012-05-23 A | 1.3.3.12.010 FS+60d | 100% |  |  | SSH-Procurement Manhours |  |  |
| 1.3.3.12.030 |  | Material receiving inspection & approval | 6d | 2012-05-23 A | 2012-05-29 A | 1.3.3.12.020 | 100% |  |  | SSH-Procurement Manhours | 852,500 |  |
|  | 13 | **Comm Concrete Ductbank Materials** |  | 2011-12-05 | 2011-12-28 |  |  |  |  |  |  |  |
| 1.3.3.13.010 |  | Place PO for comm concrete ductbank materials | 37.5d | 2011-12-05 A | 2011-12-28 A | 1.3.3.7.010 SS | 100% | 2011-07-19 | 2011-08-22 |  |  |  |
| 1.3.3.13.020 |  | Delivery of comm ductbank materials | 6d | 2011-12-06 A | 2011-12-11 A | 1.3.3.13.010 | 100% |  |  | SSH-Procurement Manhours |  |  |
| 1.3.3.13.030 |  | Material receiving inspection & approval | 6d | 2011-12-11 A | 2011-12-17 A | 1.3.3.13.020 SS | 100% |  |  | SSH-Procurement Manhours | 1,950,000 |  |
|  | 14 | **Communication CCTV System** |  | 2012-02-18 | 2012-06-20 |  |  |  |  |  |  |  |
| 1.3.3.14.010 |  | Place PO for CCTV system materials | 37.5d | 2012-02-18 A | 2012-03-22 A | 1.3.3.10.010 SS | 100% |  |  | SSH-Procurement Manhours |  |  |
| 1.3.3.14.020 |  | Delivery of CCTV system materials | 6d | 2012-06-16 A | 2012-06-20 A | 1.3.3.14.010 FS+90d | 100% |  |  | SSH-Procurement Manhours | 725,000 |  |
| 1.3.3.14.030 |  | Provision of startup spare parts & Non-material-req'ts | 6d | 2012-06-16 A | 2012-06-20 A | 1.3.3.14.020 FF | 100% |  |  | SSH-Procurement Manhours |  | 0.0428325254 |
|  | 15 | **Communication SACS System** |  | 2012-02-27 | 2012-07-11 |  |  |  |  |  |  |  |
| 1.3.3.15.010 |  | Place PO for Comm SACS System | 37.5d | 2012-02-27 A | 2012-04-01 A | 1.3.3.14.010 SS+10d | 100% |  |  | SSH-Procurement Manhours |  |  |
| 1.3.3.15.020 |  | Delivery of comm SACS system | 6.25d | 2012-07-04 A | 2012-07-09 A | 1.3.3.15.010 FS+100d | 100% |  |  | SSH-Procurement Manhours | 725,000 |  |
| 1.3.3.15.030 |  | Provision of startup spare parts & Non-material-req'ts | 6d | 2012-07-05 A | 2012-07-11 A | 1.3.3.15.020 FF+2d | 100% |  |  | SSH-Procurement Manhours |  | 0.0428325254 |
|  | 16 | **Code Blue System Materials** |  | 2011-12-11 | 2012-04-18 |  |  |  |  |  |  |  |
| 1.3.3.16.010 |  | Place PO for Code Blue System Materials | 38d | 2011-12-11 A | 2012-01-15 A | 1.3.3.13.010 SS | 100% |  |  |  |  |  |
| 1.3.3.16.020 |  | Delivery of Code Blue System Materials | 6d | 2012-04-08 A | 2012-04-14 A | 1.3.3.16.010 FS+90d | 100% |  |  |  |  |  |
| 1.3.3.16.030 |  | Provision of startup spare parts & Non-material-req'ts | 6d | 2012-04-14 A | 2012-04-18 A | 1.3.3.16.020 | 100% |  |  |  |  |  |

| ID | WBS | Activity | Duration | Start | Finish | Predecessors | Complete | Planned start | Planned finish | Resources | Cost | QTY |
| --- | --- | --- | --- | --- | --- | --- | --- | --- | --- | --- | --- | --- |
|  | 17 | **UTP Cables & Patch Panels with Accs** |  | 2012-02-18 | 2012-07-05 |  |  |  |  |  |  |  |
| 1.3.3.17.010 |  | Place PO UTP Cables & Patch Panels with accessories | 38d | 2012-02-18 A | 2012-03-24 A | 1.3.3.16.010 | 100% |  |  |  |  |  |
| 1.3.3.17.020 |  | Delivery of UTP Cables & Patch Panels with accessories | 6d | 2012-06-25 A | 2012-07-01 A | 1.3.3.17.010 FS+100d | 100% |  |  |  |  |  |
| 1.3.3.17.030 |  | Provision of startup spare parts & Non-material-req'ts | 6d | 2012-07-01 A | 2012-07-05 A | 1.3.3.17.020 | 100% |  |  |  |  |  |
|  | 18 | **Cable Vault & MDF Materials** |  | 2012-03-03 | 2012-07-05 |  |  |  |  |  |  |  |
| 1.3.3.18.010 |  | Place PO for Comm Cable Vault & MDF Materials | 38d | 2012-03-03 A | 2012-04-07 A | 1.3.3.17.010 SS+15d | 100% |  |  |  |  |  |
| 1.3.3.18.020 |  | Delivery of Comm Cable Vault & MDF Materials | 6d | 2012-06-30 A | 2012-07-05 A | 1.3.3.18.010 FS+90d | 100% |  |  |  |  |  |
| 1.3.3.18.030 |  | Provision of startup spare parts & Non-material-req'ts | 6d | 2012-06-30 A | 2012-07-05 A | 1.3.3.18.020 FF | 100% |  |  |  |  |  |
|  | 4 | **MECHANICAL / PLUMBING / HVAC WORKS** |  | 2011-06-19 | 2012-09-20 |  |  |  |  |  |  |  |
|  | 1 | **Potable / Fire water /Sewer Pipes (RTR)/(GRE) & Fittings** |  | 2011-08-13 | 2012-02-28 |  |  |  |  |  |  |  |
| 1.3.4.1.010 |  | Place PO for potable / fire water /sewer pipe (RTR) | 30d | 2011-08-13 A | 2011-09-12 A | 1.3.2.1.010 SS+7.5d | 100% | 2011-07-16 | 2011-08-11 | SSH-Procurement Manhours | 1,267,500 |  |
| 1.3.4.1.020 |  | Delivery of RTR & fittings | 6d | 2012-02-18 A | 2012-02-22 A | 1.3.4.1.010 FS+150d | 100% |  |  | SSH-Procurement Manhours | 8,872,500 |  |
| 1.3.4.1.030 |  | Provision of startup spare parts & Non-material-req'ts | 6d | 2012-02-22 A | 2012-02-28 A | 1.3.4.1.020 | 100% |  |  | SSH-Procurement Manhours | 2,535,000 | 0.7488307031 |
|  | 2 | **Potable & Fire water valves & accs** |  | 2012-02-18 | 2012-09-12 |  |  |  |  |  |  |  |
| 1.3.4.2.010 |  | Place PO for potable & fire water valves | 37.5d | 2012-02-18 A | 2012-03-22 A | 1.3.4.1.010 SS+5d | 100% |  |  | SSH-Procurement Manhours |  |  |
| 1.3.4.2.020 |  | Delivery of valves & accs | 6d | 2012-09-08 A | 2012-09-12 A | 1.3.4.2.010 FS+180d | 100% |  |  | SSH-Procurement Manhours | 3,049,000 |  |
| 1.3.4.2.030 |  | Provision of startup spare parts & Non-material-req'ts | 6d | 2012-09-08 A | 2012-09-12 A | 1.3.4.2.020 FF | 100% |  |  | SSH-Procurement Manhours |  | 0.1801329242 |
|  | 3 | **Fire Hydrants & Accs** |  | 2011-09-05 | 2012-04-15 |  |  |  |  |  |  |  |
| 1.3.4.3.010 |  | Place PO for fire hydrants & accs | 37.5d | 2011-09-05 A | 2011-09-21 A | 1.3.4.1.010 SS | 100% | 2011-12-19 | 2012-01-22 | SSH-Procurement Manhours |  |  |
| 1.3.4.3.020 |  | Delivery of fire hydranst | 6d | 2012-04-04 A | 2012-04-09 A | 1.3.4.3.010 FS+210d | 100% |  |  | SSH-Procurement Manhours | 476,000 |  |
| 1.3.4.3.030 |  | Provision of startup spare parts & Non-material-req'ts | 6d | 2012-04-09 A | 2012-04-15 A | 1.3.4.3.020 | 100% |  |  | SSH-Procurement Manhours |  | 0.0281217684 |
|  | 4 | **Submersible Pumps (Lift Station Pumps)** |  | 2011-08-28 | 2012-05-22 |  |  |  |  |  |  |  |
| 1.3.4.4.010 |  | Place PO for Submersible pumps | 37.5d | 2011-08-28 A | 2011-10-01 A | 1.3.2.5.010 SS | 100% |  |  | SSH-Procurement Manhours | 135,000 |  |
| 1.3.4.4.020 |  | Delivery of Submersible pumps | 6d | 2012-05-12 A | 2012-05-16 A | 1.3.4.4.010 FS+239d | 100% |  |  | SSH-Procurement Manhours | 945,000 |  |
| 1.3.4.4.030 |  | Provision of startup spare parts & Non-material-req'ts | 6d | 2012-05-17 A | 2012-05-22 A | 1.3.4.4.020 | 100% |  |  | SSH-Procurement Manhours | 270,000 | 0.0797571163 |

| ID | WBS | Activity | Duration | Start | Finish | Predecessors | Complete | Planned start | Planned finish | Resources | Cost | QTY |
| --- | --- | --- | --- | --- | --- | --- | --- | --- | --- | --- | --- | --- |
|  | 5 | **Sewer FRP Manholes** |  | 2011-06-19 | 2011-09-20 |  |  |  |  |  |  |  |
| 1.3.4.5.010 |  | Place PO for sewer FRP Manhole | 28.75d | 2011-06-19 A | 2011-07-19 A | 1.3.4.1.010 SS | 100% | 2011-07-16 | 2011-08-10 | SSH-Procurement Manhours | 120,000 |  |
| 1.3.4.5.020 |  | Delivery of sewer FRP Manhole | 3.75d | 2011-09-12 A | 2011-09-14 A | 1.3.4.5.010 FS+33.75d | 100% |  |  | SSH-Procurement Manhours | 840,000 |  |
| 1.3.4.5.030 |  | Provision of startup spare parts & Non-material-req'ts | 6d | 2011-09-15 A | 2011-09-20 A | 1.3.4.5.020 SS | 100% |  |  | SSH-Procurement Manhours | 240,000 | 0.0708952145 |
|  | 6 | **Sewer pipes (uPVC) & Fittings** |  | 2011-06-28 | 2011-09-20 |  |  |  |  |  |  |  |
| 1.3.4.6.010 |  | Place PO for sewer (uPVC) pipes | 33.75d | 2011-06-28 A | 2011-07-28 A | 1.3.4.1.010 SS | 100% | 2011-07-16 | 2011-08-15 | SSH-Procurement Manhours |  |  |
| 1.3.4.6.020 |  | Delivery of sewer (uPVC) pipes | 2.5d | 2011-09-13 A | 2011-09-14 A | 1.3.4.6.010 FS+30d | 100% |  |  | SSH-Procurement Manhours | 890,000 |  |
| 1.3.4.6.030 |  | Provision of startup spare parts & Non-material-req'ts | 6d | 2011-09-15 A | 2011-09-20 A | 1.3.4.6.020 SS | 100% |  |  | SSH-Procurement Manhours |  | 0.0525806174 |
|  | 7 | **Plumbing Fixtures & Accs** |  | 2012-02-27 | 2012-05-19 |  |  |  |  |  |  |  |
| 1.3.4.7.010 |  | Place PO for Plumbing fixtures & accs | 37.5d | 2012-02-27 A | 2012-04-01 A | 1.3.4.2.010 SS+10d | 100% |  |  | SSH-Procurement Manhours |  |  |
| 1.3.4.7.020 |  | Delivery of Plumbing fixtures & accs | 6d | 2012-05-14 A | 2012-05-19 A | 1.3.4.7.010 FS+45d | 100% |  |  | SSH-Procurement Manhours | 850,000 |  |
| 1.3.4.7.030 |  | Provision of startup spare parts & Non-material-req'ts | 6d | 2012-05-14 A | 2012-05-19 A | 1.3.4.7.020 FF | 100% |  |  | SSH-Procurement Manhours |  | 0.0443095091 |
|  | 8 | **Sewer pipes valve & accs** |  | 2012-02-27 | 2012-08-21 |  |  |  |  |  |  |  |
| 1.3.4.8.010 |  | Place PO for sewer valves & accs | 27.5d | 2012-02-27 A | 2012-03-22 A | 1.3.4.7.010 SS | 100% |  |  | SSH-Procurement Manhours |  |  |
| 1.3.4.8.020 |  | Delivery of sewer valves & accs | 6d | 2012-08-11 A | 2012-08-15 A | 1.3.4.8.010 FS+150d | 100% |  |  | SSH-Procurement Manhours | 290,000 |  |
| 1.3.4.8.030 |  | Provision of startup spare parts & Non-material-req'ts | 6d | 2012-08-15 A | 2012-08-21 A | 1.3.4.8.020 | 100% |  |  | SSH-Procurement Manhours |  | 0.0171330102 |
|  | 9 | **Sewer - odour control system** |  | 2011-09-18 | 2012-05-19 |  |  |  |  |  |  |  |
| 1.3.4.9.010 |  | Place PO for sewer odour control system | 30d | 2011-09-18 A | 2011-10-03 A | 1.3.4.5.010 SS | 100% | 2011-07-16 | 2011-08-11 | SSH-Procurement Manhours | 134,500 |  |
| 1.3.4.9.020 |  | Delivery of sewer odour control system | 6d | 2012-05-08 A | 2012-05-13 A | 1.3.4.9.010 FS+234d | 100% |  |  | SSH-Procurement Manhours | 941,500 |  |
| 1.3.4.9.030 |  | Provision of startup spare parts & Non-material-req'ts | 6d | 2012-05-14 A | 2012-05-19 A | 1.3.4.9.020 | 100% |  |  | SSH-Procurement Manhours | 269,000 | 0.1149093268 |
|  | 10 | **Ductile Iron pipes & Fittings** |  | 2011-10-20 | 2012-05-15 |  |  |  |  |  |  |  |
| 1.3.4.10.010 |  | Place PO for ductile iron pipes & fittings | 30d | 2011-10-20 A | 2011-11-16 A | 1.3.4.9.010 FS+50d | 100% |  |  | SSH-Procurement Manhours |  |  |
| 1.3.4.10.020 |  | Delivery of ductile iron pipes & fittings | 3.75d | 2012-05-07 A | 2012-05-10 A | 1.3.4.10.010 FS+184d | 100% |  |  | SSH-Procurement Manhours | 500,000 |  |
| 1.3.4.10.030 |  | Provision of startup spare parts & Non-material-req'ts | 6d | 2012-05-10 A | 2012-05-15 A | 1.3.4.10.020 | 100% |  |  | SSH-Procurement Manhours |  | 0.1149093268 |

| ID | WBS | Activity | Duration | Start | Finish | Predecessors | Complete | Planned start | Planned finish | Resources | Cost | QTY |
| --- | --- | --- | --- | --- | --- | --- | --- | --- | --- | --- | --- | --- |
|  | 11 | **Irrigation pipeline & fittings** |  | 2011-09-10 | 2012-01-08 |  |  |  |  |  |  |  |
| 1.3.4.11.010 |  | Place PO for irrigation pipeline & fittings | 40d | 2011-09-10 A | 2011-10-10 A | 1.3.4.9.010 SS | 100% | 2011-07-16 | 2011-08-21 | SSH-Procurement Manhours |  |  |
| 1.3.4.11.020 |  | Delivery of irrigation pipeline & fittings | 6d | 2011-12-27 A | 2012-01-01 A | 1.3.4.11.010 FS+150d | 100% |  |  | SSH-Procurement Manhours | 1,778,000 |  |
| 1.3.4.11.030 |  | Provision of startup spare parts & Non-material-req'ts | 6d | 2012-01-03 A | 2012-01-08 A | 1.3.4.11.020 | 100% |  |  | SSH-Procurement Manhours |  | 0.0354476072 |
|  | 12 | **Irrigation valves & accs** |  | 2012-02-18 | 2012-09-20 |  |  |  |  |  |  |  |
| 1.3.4.12.010 |  | Place PO for irrigation valves & accs | 30d | 2012-02-18 A | 2012-03-15 A | 1.3.4.11.010 SS+12.5d | 100% |  |  | SSH-Procurement Manhours |  |  |
| 1.3.4.12.020 |  | Delivery of irrigation valves & accs | 6d | 2012-09-10 A | 2012-09-15 A | 1.3.4.12.010 FS+190d | 100% |  |  | SSH-Procurement Manhours | 852,000 |  |
| 1.3.4.12.030 |  | Provision of startup spare parts & Non-material-req'ts | 6d | 2012-09-15 A | 2012-09-20 A | 1.3.4.12.020 | 100% |  |  | SSH-Procurement Manhours |  | 0.1199310712 |
|  | 13 | **Irrigation controllers** |  | 2012-03-17 | 2012-09-13 |  |  |  |  |  |  |  |
| 1.3.4.13.010 |  | Place PO for irrigation controllers | 30d | 2012-03-17 A | 2012-04-12 A | 1.3.4.12.010 | 100% |  |  | SSH-Procurement Manhours |  |  |
| 1.3.4.13.020 |  | Delivery of irrigation controllers | 8d | 2012-09-01 A | 2012-09-08 A | 1.3.4.13.010 FS+150d | 100% |  |  | SSH-Procurement Manhours | 325,000 |  |
| 1.3.4.13.030 |  | Provision of startup spare parts & Non-material-req'ts | 6d | 2012-09-08 A | 2012-09-13 A | 1.3.4.13.020 | 100% |  |  | SSH-Procurement Manhours |  | 0.0192007873 |
|  | 14 | **Irrigation Junction Boxes** |  | 2012-03-26 | 2012-08-26 |  |  |  |  |  |  |  |
| 1.3.4.14.010 |  | Place PO for irrigation junction boxes | 30d | 2012-03-26 A | 2012-04-22 A | 1.3.4.13.010 SS+10d | 100% |  |  | SSH-Procurement Manhours |  |  |
| 1.3.4.14.020 |  | Delivery of irrigation junction boxes | 8d | 2012-08-13 A | 2012-08-20 A | 1.3.4.14.010 FS+120d | 100% |  |  | SSH-Procurement Manhours | 565,000 |  |
| 1.3.4.14.030 |  | Provision of startup spare parts & Non-material-req'ts | 6d | 2012-08-20 A | 2012-08-26 A | 1.3.4.14.020 | 100% |  |  | SSH-Procurement Manhours |  | 0.0333798302 |
|  | 15 | **HVAC Equipments** |  | 2011-12-15 | 2012-04-24 |  |  |  |  |  |  |  |
| 1.3.4.15.010 |  | Place PO for HVAC Equipments | 30d | 2011-12-15 A | 2012-01-09 A | 1.3.2.23.010 SS | 100% | 2011-06-25 | 2011-07-21 | SSH-Procurement Manhours | 69,150 |  |
| 1.3.4.15.020 |  | Delivery of HVAC Equipments | 10d | 2012-04-07 A | 2012-04-15 A | 1.3.4.15.010 FS+95d | 100% |  |  | SSH-Procurement Manhours | 484,050 |  |
| 1.3.4.15.030 |  | Provision of startup spare parts & Non-material-req'ts | 10d | 2012-04-16 A | 2012-04-24 A | 1.3.4.15.020 | 100% |  |  | SSH-Procurement Manhours | 138,300 | 0.0408533674 |
|  | 16 | **Exhaust Fans** |  | 2011-09-03 | 2012-05-31 |  |  |  |  |  |  |  |
| 1.3.4.16.010 |  | Place PO for exhaust fans | 30d | 2011-09-03 A | 2011-10-03 A | 1.3.2.26.010 SS+22.5d | 100% | 2011-07-27 | 2011-08-23 | SSH-Procurement Manhours |  |  |
| 1.3.4.16.020 |  | Delivery of exhasust fans | 10d | 2012-05-14 A | 2012-05-22 A | 1.3.4.16.010 FS+240d | 100% |  |  | SSH-Procurement Manhours | 400,640 |  |
| 1.3.4.16.030 |  | Provision of startup spare parts & Non-material-req'ts | 10d | 2012-05-23 A | 2012-05-31 A | 1.3.4.16.020 | 100% |  |  | SSH-Procurement Manhours |  | 0.0236695489 |

| ID | WBS | Activity | Duration | Start | Finish | Predecessors | Complete | Planned start | Planned finish | Resources | Cost | QTY |
| --- | --- | --- | --- | --- | --- | --- | --- | --- | --- | --- | --- | --- |
|  | C.1.4 | **CONSTRUCTION** |  | 2011-01-20 | 2014-01-04 |  |  |  |  |  |  |  |
|  | 1 | **MOBILIZATION** |  | 2011-01-20 | 2013-01-09 |  |  |  |  |  |  |  |
|  | 1 | **Mobilization** |  | 2011-01-20 | 2012-01-15 |  |  |  |  |  |  |  |
|  | 2 | **Mobilization of Temp. Fac. @ Zone 4** |  | 2011-01-20 | 2012-01-15 |  |  |  |  |  |  |  |
| 1.4.1.1.110 |  | Install of temp fence at zone 4 | 40d | 2011-01-20 A | 2011-02-22 A | M1.00 | 100% | 2011-01-09 | 2011-02-14 | SSH-Construction Manhours [1678 h] | 250,000 |  |
| 1.4.1.1.220 |  | Mobilization of equipments | 30d | 2011-02-01 A | 2011-09-20 A | 1.4.1.1.130 SS+12.5d | 100% | 2011-02-01 | 2011-02-28 | SSH-Construction Manhours [19982 h] | 3,250,000 |  |
| 1.4.1.1.230 |  | Mobilization of Manpower | 31.25d | 2011-02-10 A | 2012-01-15 A | 1.4.1.1.220 SS+10d, 1.4.1.1.110 SS+10d | 100% | 2011-02-10 | 2011-03-10 | SSH-Construction Manhours [4920 h] | 800,000 | 0.2363173816 |
| 1.4.1.1.120 |  | Construction of SAPMT office | 31.25d | 2011-02-26 A | 2011-03-20 A | 1.4.1.1.210 SS+15d | 100% | 2011-02-01 | 2011-03-01 | SSH-Construction Manhours [4612 h] | 750,000 |  |
| 1.4.1.1.130 |  | Const/Install of laydown yards | 40d | 2011-02-26 A | 2011-03-24 A | 1.4.1.1.110 SS+12.5d | 100% | 2011-01-20 | 2011-02-26 | SSH-Construction Manhours [3074 h] | 500,000 |  |
| 1.4.1.1.210 |  | Construction of contractor site offices | 40d | 2011-02-26 A | 2011-03-20 A | 1.4.1.1.110 SS+10d | 100% | 2011-01-18 | 2011-02-23 | SSH-Construction Manhours [3074 h] | 500,000 |  |
| 1.4.1.1.150 |  | Install water supply system for offices | 15d | 2011-03-01 A | 2011-03-14 A | 1.4.1.1.140 SS+12.5d | 100% | 2011-02-22 | 2011-03-07 | SSH-Construction Manhours [615 h] | 100,000 |  |
| 1.4.1.1.140 |  | Install electric lighting system for site offices | 20d | 2011-03-10 A | 2011-03-31 A | 1.4.1.1.210 SS+25d | 100% | 2011-02-10 | 2011-02-28 | SSH-Construction Manhours [1537 h] | 250,000 |  |
| 1.4.1.1.160 |  | Install sanitary system for offices | 11.25d | 2011-03-15 A | 2011-03-28 A | 1.4.1.1.150 SS+6.25d | 100% | 2011-02-28 | 2011-03-09 | SSH-Construction Manhours [461 h] | 75,000 |  |
| 1.4.1.1.170 |  | Install fire protection sytem for offices | 8.75d | 2011-03-24 A | 2011-03-28 A | 1.4.1.1.160 SS+2.5d | 100% | 2011-03-02 | 2011-03-09 | SSH-Construction Manhours [153 h] | 25,000 |  |
| 1.4.1.1.180 |  | Install furniture & accs in offices | 8.75d | 2011-04-12 A | 2011-05-10 A | 1.4.1.1.170 SS | 100% | 2011-03-02 | 2011-03-09 | SSH-Construction Manhours [768 h] | 125,000 |  |
| 1.4.1.1.190 |  | Install computers / equipments & accs in offices | 8.75d | 2011-05-22 A | 2011-05-30 A | 1.4.1.1.180 SS | 100% | 2011-03-02 | 2011-03-09 | SSH-Construction Manhours [922 h] | 150,000 |  |
| 1.4.1.1.200 |  | Install telecomm system for offices | 8.75d | 2011-05-22 A | 2011-05-30 A | 1.4.1.1.190 SS | 100% | 2011-03-02 | 2011-03-09 | SSH-Construction Manhours [461 h] | 75,000 |  |
|  | 2 | **Demolition of existing structure** |  | 2011-06-12 | 2011-09-26 |  |  |  |  |  |  |  |
|  | 1 | **Demolition of existing structure** |  | 2011-06-12 | 2011-09-26 |  |  |  |  |  |  |  |
|  | 1 | **Zone 2** |  | 2011-06-13 | 2011-07-25 |  |  |  |  |  |  |  |
| 1.4.1.2.1.010 |  | Demolition of existing laydown yard etc. | 30d | 2011-06-13 A | 2011-06-25 A | 1.4.1.1.200 | 100% | 2011-07-24 | 2011-08-20 | SSH-Construction Manhours [8083 h] | 525,000 |  |
| 1.4.1.2.1.020 |  | Demolition of existing asphalt pavement | 30d | 2011-07-03 A | 2011-07-25 A | 1.4.1.2.1.010 | 100% | 2011-08-21 | 2011-09-17 | SSH-Construction Manhours [10086 h] | 655,000 | 0.1934848562 |
|  | 2 | **Zone 3** |  | 2011-06-12 | 2011-09-26 |  |  |  |  |  |  |  |
| 1.4.1.2.2.010 |  | Demolition of existing concrete pad/structure | 30d | 2011-06-12 A | 2011-06-25 A | 1.4.1.2.1.010 SS | 100% | 2011-06-09 | 2011-07-06 | SSH-Construction Manhours [3195 h] | 207,500 |  |
| 1.4.1.2.2.020 |  | Demolition of septic tank | 30d | 2011-07-07 A | 2011-08-01 A | 1.4.1.2.2.010 | 100% | 2011-07-07 | 2011-08-03 | SSH-Construction Manhours [270 h] | 17,500 |  |
| 1.4.1.2.2.030 |  | Demolition of bldg foundations | 30d | 2011-08-08 A | 2011-09-04 A | 1.4.1.2.2.020 | 100% | 2011-08-04 | 2011-08-31 | SSH-Construction Manhours [23867 h] | 1,550,000 |  |
| 1.4.1.2.2.040 |  | Demolition of generator shed foundations | 30d | 2011-09-12 A | 2011-09-26 A | 1.4.1.2.2.030 | 100% | 2011-09-01 | 2011-09-28 | SSH-Construction Manhours [693 h] | 45,000 | 0.0132928527 |

| ID | WBS | Activity | Duration | Start | Finish | Predecessors | Complete | Remaining | Planned start | Planned finish | Total float | Free float | Resources | Cost | QTY |
| --- | --- | --- | --- | --- | --- | --- | --- | --- | --- | --- | --- | --- | --- | --- | --- |
|  | 3 | **Site Preparation** |  | 2011-04-12 | 2013-01-09 |  |  |  |  |  |  |  |  |  |  |
|  | 1 | **Site Topographic Survey & Layout** |  | 2011-05-07 | 2011-06-22 |  |  |  |  |  |  |  |  |  |  |
|  | 1 | **Site Topographic Survey & Layout** |  | 2011-05-07 | 2011-06-22 |  |  |  |  |  |  |  |  |  |  |
| 1.4.1.3.010 |  | Site topographic survey & survey layout & stacking | 31.25d | 2011-05-07 A | 2011-06-05 A | 1.4.1.3.3.010 SS+25d, M2.01, M2.02, M2.03, 1.4.1.1.200 | 100% |  | 2011-05-03 | 2011-05-31 |  |  | SSH-Construction Manhours [1420 h] | 120,000 |  |
| 1.4.1.3.020 |  | Geotechnical Soil Investigation | 31.25d | 2011-05-25 A | 2011-06-22 A | 1.4.1.3.010 SS+30d | 100% |  | 2011-05-31 | 2011-06-28 |  |  | SSH-Construction Manhours [7217 h] | 1,707,145 | 0.504285341 |
|  | 2 | **Zone 1** |  | 2011-04-12 | 2013-01-09 |  |  |  |  |  |  |  |  |  |  |
|  | 2 | **Site Preparation** |  | 2011-04-12 | 2013-01-09 |  |  |  |  |  |  |  |  |  |  |
| Z1.1010 |  | Site clearing/grubbing/disposal zone1 | 15d | 2011-04-12 A | 2011-04-25 A | 1.4.1.3.1.010 | 100% |  | 2011-04-10 | 2011-04-23 |  |  | SSH-Construction Manhours [1461 h] | 85,483 |  |
| Z1.1020 |  | Cutting/backfilling/grading zone1 | 25d | 2011-04-25 A | 2011-05-12 A | Z1.1010, 1.3.1.15.020 SS | 100% |  | 2011-04-24 | 2011-05-16 |  |  | SSH-Construction Manhours [14602 h] | 854,826 |  |
| Z1.1030 |  | Install temporary access for Zone 1 | 210d | 2011-05-17 A | 2013-01-09 | Z1.1020 | 50% | 105d | 2011-05-17 | 2011-11-28 | -182.5d | 0d | SSH-Construction Manhours [3843 h] | 225,000 |  |
|  | 3 | **Zone 3** |  | 2011-05-23 | 2012-12-10 |  |  |  |  |  |  |  |  |  |  |
|  | 1 | **A3-1** |  | 2011-05-23 | 2012-10-09 |  |  |  |  |  |  |  |  |  |  |
| Z3.1010 |  | Site Clearing/Grubbing/Disposal | 12.5d | 2011-05-23 A | 2011-09-04 A | 1.4.1.3.020 FS+7.5d, M2.04 | 100% |  | 2011-07-06 | 2011-07-17 |  |  | SSH-Construction Manhours [11066 h] | 552,217 |  |
| Z3.1020 |  | Backfill/Compaction of soil upto desired level | 150d | 2011-07-18 A | 2012-10-09 | Z3.1010 FF, 1.3.1.15.020 SS | 96% | 5.37d | 2011-07-18 | 2011-12-04 | -97.5d | 0d | SSH-Construction Manhours [47149 h] | 2,325,125 |  |
|  | 2 | **A3-2** |  | 2011-07-20 | 2012-02-20 |  |  |  |  |  |  |  |  |  |  |
| Z3.2030 |  | Backfill/Compaction of soil upto desired level | 231d | 2011-07-20 A | 2012-02-20 A | Z3.1020 SS, Z3.2020 FF | 100% |  |  |  |  |  | SSH-Construction Manhours [47149 h]; Grader [200 h] | 3,692,846 |  |
| Z3.2020 |  | Site Clearing/Grubbing/Disposal | 12.5d | 2011-08-15 A | 2011-10-04 A | Z3.1020 SS | 100% |  | 2011-07-09 | 2011-07-19 |  |  | SSH-Construction Manhours [10966 h] | 877,050 |  |
|  | 3 | **A3-3** |  | 2011-07-26 | 2012-10-15 |  |  |  |  |  |  |  |  |  |  |
| Z3.3020 |  | Backfill/Compaction of soil upto desired level | 150d | 2011-07-26 A | 2012-10-15 | Z3.1020 SS, Z3.3010 FF | 92% | 12.45d | 2011-07-26 | 2011-12-12 | -76.38d | 0d | SSH-Construction Manhours [47149 h] | 4,103,163 |  |
| Z3.3010 |  | Site Clearing/Grubbing/Disposal | 18.75d | 2011-09-13 A | 2011-10-20 A | Z3.2020 SS | 100% |  | 2011-07-09 | 2011-07-25 |  |  | SSH-Construction Manhours [11313 h] | 974,501 |  |
|  | 4 | **A3-4** |  | 2011-08-15 | 2012-12-10 |  |  |  |  |  |  |  |  |  |  |
| Z3.4020 |  | Backfill/Compaction of soil upto desired level | 150d | 2011-08-15 A | 2012-12-10 | Z3.4010 FF | 52% | 71.49d | 2011-08-15 | 2012-01-01 | -22.49d | 0d | SSH-Construction Manhours [73288 h] | 4,177,517 |  |
| Z3.4010 |  | Site Clearing/Grubbing/Disposal | 8.75d | 2011-09-30 A | 2011-11-14 A | Z3.3020 SS+12.5d | 100% |  | 2011-08-07 | 2011-08-14 |  |  | SSH-Construction Manhours [10828 h] | 552,217 |  |
|  | 5 | **A3-5** |  | 2011-08-25 | 2012-12-09 |  |  |  |  |  |  |  |  |  |  |
| Z3.5020 |  | Backfill/Compaction of soil upto desired level | 150d | 2011-08-25 A | 2012-12-09 | Z3.5010 | 53% | 70.2d | 2011-08-25 | 2012-01-11 | -48.5d | 0d | SSH-Construction Manhours [82182 h] | 3,083,344 |  |
| Z3.5010 |  | Site Clearing/Grubbing/Disposal | 7.5d | 2011-10-20 A | 2011-11-15 A | Z3.4010 FS+3.75d, 1.4.1.2.2.040 | 100% |  | 2011-08-18 | 2011-08-24 |  |  | SSH-Construction Manhours [11313 h] | 292,352 |  |

| ID | WBS | Activity | Duration | Start | Finish | Predecessors | Complete | Remaining | Planned start | Planned finish | Total float | Free float | Resources | Cost |
| --- | --- | --- | --- | --- | --- | --- | --- | --- | --- | --- | --- | --- | --- | --- |
|  | 2 | **UTILITIES & SERVICES WORKS** |  | 2011-01-28 | 2013-07-03 |  |  |  |  |  |  |  |  |  |
|  | 1 | **PW / FW / CTMU(Cooling Tower Make Up) / Irrigation / Sea water Line** |  | 2011-10-30 | 2013-06-17 |  |  |  |  |  |  |  |  |  |
|  | 1 | **Zone 1** |  | 2012-06-28 | 2013-06-17 |  |  |  |  |  |  |  |  |  |
|  | 1 | **A1** |  | 2012-06-28 | 2013-06-17 |  |  |  |  |  |  |  |  |  |
| Z1.1040 |  | Excavation for water line & Valve boxes(2) | 60d | 2012-06-28 A | 2013-05-11 | Z1.1030 FS+100d, 1.4.1.2.1.020 SS | 50% | 30d | 2012-06-28 | 2012-08-23 | -182.5d | 0d | SSH-Construction Manhours [1189 h]; Excavator [200 h]; Dump Truck [200 h] | 4,800 |
| Z1.1050 |  | Construction of vale boxes(2) | 60d | 2012-07-17 A | 2013-05-29 | Z1.1040 FF+20d | 78% | 13.2d | 2012-07-17 | 2012-09-11 | -182.5d | 0d | SSH-Construction Manhours [3184 h] | 26,432 |
| Z1.1060 |  | Install PW/FW/CTMU line +Irrigation line (375LM) | 60d | 2012-08-05 A | 2013-06-17 | Z1.1050 FF+20d | 36% | 38.1d | 2012-08-05 | 2012-09-30 | -182.5d | 0d | SSH-Construction Manhours [5093 h] | 130,000 |
|  | 2 | **Zone 3** |  | 2011-10-30 | 2013-03-30 |  |  |  |  |  |  |  |  |  |
|  | 1 | **A3-1** |  | 2012-03-14 | 2013-01-30 |  |  |  |  |  |  |  |  |  |
| Z3.1070 |  | Construction of Valve boxes for water line (4) | 90d | 2012-03-14 A | 2012-11-08 | Z2.2270 | 85% | 13.5d | 2012-03-14 | 2012-06-06 | -3.06d | 0d | SSH-Construction Manhours [2257 h]; Excavator [170 h]; Dump Truck [170 h] | 52,864 |
| Z3.1230 |  | Construction of Valve boxes for water line (7) | 90d | 2012-04-17 A | 2012-11-08 | Z2.2230 SS, Z2.2270 | 85% | 13.5d | 2012-04-17 | 2012-07-09 | -34.81d | 0d | SSH-Construction Manhours [2122 h] | 92,512 |
| Z3.1240 |  | Installation of PW/FW/CTMU line-A(825) + Irrigation line | 25d | 2012-04-29 A | 2012-11-01 | Z3.1230 SS+12.5d | 75% | 6.25d | 2012-04-29 | 2012-05-21 | -34.81d | 0d | SSH-Construction Manhours [6366 h] | 75,000 |
| Z3.1250 |  | Installation of PW/FW/CTMU line-B(825) + Irrigation line | 25d | 2012-05-17 A | 2012-11-20 | Z3.1240 FF+20d | 75% | 6.25d | 2012-05-17 | 2012-06-09 | -34.81d | 0d | SSH-Construction Manhours [6366 h] | 75,000 |
| Z3.1260 |  | Installation of PW/FW/CTMU line-C(825) + Irrigation line | 25d | 2012-06-05 A | 2012-12-09 | Z3.1250 FF+20d | 75% | 6.25d | 2012-06-05 | 2012-06-27 | -34.81d | 0d | SSH-Construction Manhours [6366 h] | 75,000 |
| Z3.1080 |  | Installation of PW/FW/CTMU line-A(375LM) + irrigation line | 25d | 2012-06-06 A | 2012-11-13 | Z3.1070, 1.3.4.1.030, 1.3.4.11.030 | 80% | 5d | 2012-06-06 | 2012-06-30 | -3.06d | 0d | SSH-Construction Manhours [5093 h] | 75,000 |
| Z3.1270 |  | Installation of PW/FW/CTMU line-D(825) + Irrigation line | 25d | 2012-06-24 A | 2012-12-27 | Z3.1260 FF+20d | 69% | 7.75d | 2012-06-24 | 2012-07-16 | -34.81d | 0d | SSH-Construction Manhours [6366 h] | 75,000 |
| Z3.1090 |  | Installation of PW/FW/CTMU line-B(375LM) + irrigation line | 25d | 2012-06-30 A | 2012-11-18 | Z3.1080 | 76% | 6d | 2012-06-30 | 2012-07-23 | -3.06d | 31.75d | SSH-Construction Manhours [5093 h] | 75,000 |
| Z3.1280 |  | Instalaltion of seawater line (825LM) A | 25d | 2012-07-12 A | 2013-01-15 | Z3.1270 FF+20d | 75% | 6.25d | 2012-07-12 | 2012-08-04 | -34.81d | 0d | SSH-Construction Manhours [1062 h] | 130,421 |
| Z3.1290 |  | Instalaltion of seawater line (825LM) B | 25d | 2012-08-05 A | 2013-01-15 | Z3.1280 SS+25d | 75% | 6.25d | 2012-08-05 | 2012-08-27 | -34.81d | 0d | SSH-Construction Manhours [1062 h] | 130,421 |
| Z3.1300 |  | Instalaltion of seawater line (825LM) C | 25d | 2012-08-28 A | 2013-01-15 | Z3.1290 SS+25d | 75% | 6.25d | 2012-08-28 | 2012-09-19 | -34.81d | 0d | SSH-Construction Manhours [1062 h] | 130,421 |
| Z3.1310 |  | Instalaltion of seawater line (825LM) D | 25d | 2012-09-11 A | 2013-01-15 | Z3.1300 SS+15d, Z3.1090 | 75% | 6.25d | 2012-09-11 | 2012-10-03 | -34.81d | 0d | SSH-Construction Manhours [1062 h] | 130,421 |
| Z3.1340 |  | Install valves | 31d | 2012-11-08 | 2012-12-06 | Z3.1230, 1.3.4.2.030, 1.3.4.12.030 |  |  |  |  | 23.94d | 120.62d | SSH-Construction Manhours [2122 h] | 176,971 |
| Z3.1320 |  | Install fire hydrants | 45d | 2012-12-18 | 2013-01-29 | Z3.1310 FF+15d, 1.3.4.3.030, Z3.1090 |  |  |  |  | -34.81d | 0d | SSH-Construction Manhours [1479 h] | 200,000 |
| Z3.1330 |  | Install irrigation system & accs | 30d | 2013-01-02 | 2013-01-30 | Z3.1320 FF+2d, 1.3.4.13.030, 1.3.4.14.030 |  |  |  |  | -34.81d | 61.88d | SSH-Construction Manhours [1357 h] | 175,000 |

| ID | WBS | Activity | Duration | Start | Finish | Predecessors | Complete | Remaining | Planned start | Planned finish | Total float | Free float | Resources | Cost |
| --- | --- | --- | --- | --- | --- | --- | --- | --- | --- | --- | --- | --- | --- | --- |
|  | 2 | **A3-2** |  | 2011-10-30 | 2013-03-30 |  |  |  |  |  |  |  |  |  |
| Z3.2170 |  | Install PW/FW/CTMU line + Irrigation line A(1200LM) | 31.25d | 2011-10-30 A | 2012-10-10 | Z2.2270 SS | 77% | 7.19d | 2011-10-30 | 2011-11-27 | -96.69d | 0d | SSH-Construction Manhours [6366 h] | 75,000 |
| Z3.2180 |  | Install PW/FW/CTMU line + Irrigation line B(1200LM) | 31.25d | 2012-02-20 A | 2012-10-11 | Z3.2170 SS | 75% | 7.81d | 2012-02-20 | 2012-03-20 | -70.06d | 0d | SSH-Construction Manhours [6366 h] | 75,000 |
| Z3.2190 |  | Install PW/FW/CTMU line + Irrigation line C(1200LM) | 31.25d | 2012-02-25 A | 2012-10-30 | Z3.2180 FF+20d | 75% | 7.81d | 2012-02-25 | 2012-03-24 | -70.06d | 0d | SSH-Construction Manhours [6366 h] | 75,000 |
| Z3.2210 |  | Install Seawater line (1650LM) A | 25d | 2012-03-06 A | 2012-10-20 | Z3.2180 | 62% | 9.5d | 2012-03-06 | 2012-03-28 | -22.69d | 0d | SSH-Construction Manhours [2122 h] | 130,421 |
| Z3.2160 |  | Construction for valve boxes (11) | 90d | 2012-03-11 A | 2012-11-13 | Z3.2170 | 60% | 36d | 2012-03-11 | 2012-06-03 | -96.69d | 0d | SSH-Construction Manhours [3969 h]; Excavator [220 h]; Dump Truck [220 h] | 145,376 |
| Z3.2200 |  | Install PW/FW/CTMU line + Irrigation line D(1200LM) | 31.25d | 2012-03-25 A | 2012-11-05 | Z3.2190 | 78% | 6.81d | 2012-03-25 | 2012-04-22 | -8.5d | 14.19d | SSH-Construction Manhours [6366 h] | 75,000 |
| Z3.2220 |  | Install Seawater line (1650LM) B | 25d | 2012-03-25 A | 2012-11-07 | Z3.2210 FF+20d | 63% | 9.25d | 2012-03-25 | 2012-04-16 | -22.69d | 0d | SSH-Construction Manhours [2122 h] | 130,421 |
| Z3.2230 |  | Install Seawater line (1650LM) C | 25d | 2012-04-23 A | 2012-11-26 | Z3.2220 FF+20d, Z3.2200 | 66% | 8.5d | 2012-04-23 | 2012-05-15 | -22.69d | 0d | SSH-Construction Manhours [1062 h] | 130,421 |
| Z3.2240 |  | Install Seawater line (1650LM) D | 25d | 2012-05-12 A | 2012-12-15 | Z3.2230 FF+20d | 54% | 11.53d | 2012-05-12 | 2012-06-03 | -22.69d | 0d | SSH-Construction Manhours [1062 h] | 130,421 |
| Z3.2250 |  | Install Seawater line (1650LM) E | 25d | 2012-05-30 A | 2013-01-02 | Z3.2240 FF+20d | 47% | 13.25d | 2012-05-30 | 2012-06-21 | -22.69d | 0d | SSH-Construction Manhours [1062 h] | 130,421 |
| Z3.2260 |  | Install seawater line (600LM)A | 12.5d | 2012-06-23 A | 2013-01-09 | Z3.2250 | 47% | 6.62d | 2012-06-23 | 2012-07-03 | -22.69d | 0d | SSH-Construction Manhours [1062 h] | 130,421 |
| Z3.2270 |  | Install seawater line (600LM)B | 12.5d | 2012-07-04 A | 2013-01-12 | Z3.2260 | 75% | 3.12d | 2012-07-04 | 2012-07-15 | -22.69d | 0d | SSH-Construction Manhours [1062 h] | 130,421 |
| Z3.2280 |  | Install seawater line (600LM)C | 12.5d | 2012-07-16 A | 2013-01-15 | Z3.2270 | 75% | 3.12d | 2012-07-16 | 2012-07-26 | -22.69d | 0d | SSH-Construction Manhours [1062 h] | 130,421 |
| Z3.2290 |  | Install fire hydrants | 52.5d | 2012-11-27 | 2013-01-15 | Z3.2280 FF, 1.3.4.3.030 |  |  |  |  | -22.69d | 0d | SSH-Construction Manhours [896 h] | 200,000 |
| Z3.2300 |  | Install irrigation system & accs | 45d | 2012-12-09 | 2013-01-20 | Z3.2290 FF+5d |  |  |  |  | -22.69d | 74d | SSH-Construction Manhours [896 h] | 175,000 |
| Z3.2310 |  | Install valves | 26d | 2013-03-05 | 2013-03-30 | Z3.2160 FS+120d, 1.3.4.2.030 |  |  |  |  | -96.69d | 0d | SSH-Construction Manhours [1235 h] | 176,971 |
|  | 3 | **A3-3** |  | 2012-03-10 | 2013-03-05 |  |  |  |  |  |  |  |  |  |
| Z3.3250 |  | Installation of PW/FW/CTMU line + Irrigation line B | 25d | 2012-03-10 A | 2012-10-20 | Z3.3240 | 63% | 9.25d | 2012-03-10 | 2012-04-02 | 44.19d | 0d | SSH-Construction Manhours [2546 h] | 75,000 |
| Z3.3235 |  | Construction of valve boxes (12) A | 90d | 2012-03-25 A | 2012-11-12 | Z3.2190 | 85% | 13.5d | 2012-03-25 | 2012-06-16 | -70.06d | 0d | SSH-Construction Manhours [2752 h]; Excavator [250 h]; Dump Truck [250 h] | 79,296 |
| Z3.3260 |  | Installation of PW/FW/CTMU line + Irrigation line C | 25d | 2012-04-02 A | 2012-10-25 | Z3.3250 | 75% | 6.25d | 2012-04-02 | 2012-04-25 | 44.19d | 0d | SSH-Construction Manhours [2546 h] | 75,000 |
| Z3.3240 |  | Installation of PW/FW/CTMU line + Irrigation line A | 25d | 2012-07-19 A | 2012-10-11 | Z3.2180 FF | 75% | 6.25d | 2012-07-19 | 2012-08-11 | 1.88d | 0d | SSH-Construction Manhours [1698 h] | 75,000 |
| Z3.3270 |  | Install fire hydrants | 25d | 2012-10-25 | 2012-11-18 | Z3.3260, 1.3.4.3.030 |  |  |  |  | 44.19d | 226.69d | SSH-Construction Manhours [1019 h] | 200,000 |
| Z3.3236 |  | Construction of valve boxes (12) B | 90d | 2012-11-12 | 2013-02-04 | Z3.3235 |  |  |  |  | -70.06d | 0d | SSH-Construction Manhours [1273 h]; Excavator [250 h]; Dump Truck [250 h] | 79,296 |
| Z3.3280 |  | Install valves | 31.25d | 2013-02-04 | 2013-03-05 | Z3.3236 |  |  |  |  | -70.06d | 112.44d | SSH-Construction Manhours [643 h] | 176,971 |

| ID | WBS | Activity | Duration | Start | Finish | Predecessors | Complete | Remaining | Planned start | Planned finish | Total float | Free float | Resources | Cost |
| --- | --- | --- | --- | --- | --- | --- | --- | --- | --- | --- | --- | --- | --- | --- |
|  | 4 | **A3-4** |  | 2012-03-10 | 2012-12-27 |  |  |  |  |  |  |  |  |  |
| Z3.4030 |  | Install seawater line (1050LM)A | 31.25d | 2012-03-10 A | 2012-10-18 | Z3.3240 | 75% | 7.81d | 2012-03-10 | 2012-04-08 | 1.88d | 0d | SSH-Construction Manhours [2122 h] | 130,421 |
| Z3.4040 |  | Install seawater line (1050LM)B | 31.25d | 2012-04-02 A | 2012-11-11 | Z3.4030 FF+25d | 75% | 7.81d | 2012-04-02 | 2012-05-01 | 1.88d | 0d | SSH-Construction Manhours [2122 h] | 130,421 |
| Z3.4050 |  | Install seawater line (1050LM)C | 31.25d | 2012-04-25 A | 2012-12-04 | Z3.4040 FF+25d | 75% | 7.81d | 2012-04-25 | 2012-05-24 | 1.88d | 0d | SSH-Construction Manhours [2122 h] | 130,421 |
| Z3.4060 |  | Install seawater line (1050LM)D | 31.25d | 2012-05-19 A | 2012-12-27 | Z3.4050 FF+25d | 75% | 7.81d | 2012-05-19 | 2012-06-17 | 1.88d | 158.12d | SSH-Construction Manhours [2122 h] | 130,421 |
|  | 5 | **A3-5** |  | 2012-04-17 | 2012-11-14 |  |  |  |  |  |  |  |  |  |
| Z3.5060 |  | Install seawater line (600LM)A | 25d | 2012-04-17 A | 2012-11-03 | Z3.4030 FS+10d | 75% | 6.25d | 2012-04-17 | 2012-05-10 | 48.12d | 0d | SSH-Construction Manhours [3820 h] | 130,421 |
| Z3.5070 |  | Install seawater line (600LM)B | 25d | 2012-05-10 A | 2012-11-08 | Z3.5060 | 75% | 6.25d | 2012-05-10 | 2012-06-03 | 48.12d | 0d | SSH-Construction Manhours [3820 h] | 130,421 |
| Z3.5080 |  | Install seawater line (600LM)C | 25d | 2012-06-03 A | 2012-11-14 | Z3.5070 | 75% | 6.25d | 2012-06-03 | 2012-06-26 | 48.12d | 204.38d | SSH-Construction Manhours [3820 h] | 130,421 |
|  | 3 | **Zone 2** |  | 2011-11-12 | 2013-04-06 |  |  |  |  |  |  |  |  |  |
|  | 1 | **A2-1** |  | 2011-12-24 | 2013-02-12 |  |  |  |  |  |  |  |  |  |
| Z2.1080 |  | Install PW/FW/CTMU line+irrigation line (1200LM)A+Seawater | 31.25d | 2011-12-24 A | 2012-10-11 | Z2.1060 SS | 75% | 7.81d | 2011-12-24 | 2012-01-21 | -17.88d | 0d | SSH-Construction Manhours [6366 h] | 244,000 |
| Z2.1090 |  | Install PW/FW/CTMU line+irrigation line (1200LM)B+Seawater | 31.25d | 2012-01-22 A | 2012-10-09 | Z2.1100 SS | 82% | 5.62d | 2012-01-22 | 2012-02-19 | 0.88d | 18.75d | SSH-Construction Manhours [3184 h] | 244,000 |
| Z2.1100 |  | Install PW/FW/CTMU line+irrigation line (1200LM)C+Seawater | 31.25d | 2012-02-20 A | 2012-10-27 | Z2.1080 SS | 22% | 24.38d | 2012-02-20 | 2012-03-19 | -17.88d | 0d | SSH-Construction Manhours [3184 h] | 244,000 |
| Z2.1060 |  | Excavation for valve boxes & water line trench | 25d | 2012-10-04 | 2012-10-27 | Z3.5020 SS |  |  |  |  | -48.5d | 0d | SSH-Construction Manhours [1189 h]; Excavator [200 h]; Dump Truck [200 h] | 22,894 |
| Z2.1110 |  | Install fire hydrants | 60d | 2012-10-27 | 2012-12-22 | 1.3.4.3.030, Z2.1100, Z2.1090, Z2.1080, Z2.1100 FF |  |  |  |  | -17.88d | 30.62d | SSH-Construction Manhours [2292 h] | 75,000 |
| Z2.1070 |  | Construction of vale boxes for water line (5) | 90d | 2012-10-28 | 2013-01-19 | Z2.1060 |  |  |  |  | -48.5d | 0d | SSH-Construction Manhours [3009 h] | 66,080 |
| Z2.1120 |  | Install valves | 26d | 2013-01-20 | 2013-02-12 | Z2.1070, 1.3.4.2.030, Z2.1110 |  |  |  |  | -48.5d | 134d | SSH-Construction Manhours [1235 h] | 50,000 |
|  | 2 | **A2-2** |  | 2011-11-12 | 2013-04-06 |  |  |  |  |  |  |  |  |  |
| Z2.2250 |  | Install PW/FW/CTMU line +irrigation line (225LM)A | 15d | 2011-11-12 A | 2012-10-07 | Z3.3020 SS | 75% | 3.75d | 2011-11-12 | 2011-11-24 | -76.38d | 0d | SSH-Construction Manhours [3057 h] | 57,800 |
| Z2.2252 |  | Excavation for water line trench & valve boxesB | 25d | 2012-02-29 A | 2012-10-25 | Z2.2250 | 20% | 20d | 2012-02-29 | 2012-03-24 | -46.25d | 58.55d | SSH-Construction Manhours [713 h]; Dump Truck [120 h]; Excavator [120 h] | 22,894 |
| Z2.2262 |  | Excavation for water line trench & valve boxesC | 18.75d | 2012-03-14 A | 2012-11-08 | Z2.2270 | 23% | 14.44d | 2012-03-14 | 2012-04-01 | -80.38d | 0d | SSH-Construction Manhours [509 h]; Excavator [150 h]; Dump Truck [150 h] | 22,894 |
| Z2.2270 |  | Install PW/FW/CTMU line +irrigation line (825LM)C | 31.25d | 2012-03-15 A | 2012-10-27 | Z2.2250 FF | 23% | 24.06d | 2012-03-15 | 2012-04-12 | -96.69d | 0d | SSH-Construction Manhours [6366 h] | 57,800 |
| Z2.2264 |  | Construction of valve boxesC (2) | 60d | 2012-04-01 A | 2012-11-22 | Z2.2262 | 75% | 15d | 2012-04-01 | 2012-05-27 | -80.38d | 0d | SSH-Construction Manhours [2122 h] | 26,432 |
| Z2.2240 |  | Construction of valve boxesA (2) | 90d | 2012-05-10 A | 2013-01-16 | Z2.2230 | 3% | 87.3d | 2012-05-10 | 2012-08-01 | -104.8d | 0d | SSH-Construction Manhours [2122 h] | 26,432 |
| Z2.2300 |  | Installation of irrigation line to existing facilities(900LM)B | 31.25d | 2012-07-12 A | 2013-02-05 | Z2.2290 | 6% | 29.38d | 2012-07-12 | 2012-08-11 | -80.38d | 0d | SSH-Construction Manhours [1273 h] | 57,800 |
| Z2.2260 |  | Install PW/FW/CTMU line +irrigation line (450LM)B | 30d | 2012-08-26 A | 2013-03-09 | Z2.2254 FF+25d | 44% | 16.8d | 2012-08-26 | 2012-09-22 | -104.8d | 0d | SSH-Construction Manhours [4584 h] | 57,800 |
| Z2.2230 |  | Excavation for water line trench & valve boxesA | 25d | 2012-10-04 | 2012-10-27 | 1.4.1.3.2.010 FS+18.75d, M2.07 |  |  |  |  | -104.8d | 0d | SSH-Construction Manhours [594 h]; Excavator [100 h]; Dump Truck [100 h] | 22,894 |
| Z2.2280 |  | Excavation for irrigation line to exisitng facilities | 18.75d | 2012-11-22 | 2012-12-10 | Z2.2264 |  |  |  |  | -80.38d | 0d | SSH-Construction Manhours [892 h]; Excavator [150 h]; Dump Truck [150 h] | 22,894 |
| Z2.2290 |  | Installation of irrigation line to existing facilities(900LM)A | 31.25d | 2012-12-10 | 2013-01-08 | Z2.2280 |  |  |  |  | -80.38d | 0d | SSH-Construction Manhours [1273 h] | 57,800 |
| Z2.2254 |  | Construction of valve boxesB (2) | 60d | 2012-12-19 | 2013-02-13 | Z2.2252, Z2.2240 FF+30d |  |  |  |  | -104.8d | 0d | SSH-Construction Manhours [2122 h] | 26,432 |
| Z2.2310 |  | Install fire hydrants | 56.25d | 2013-01-21 | 2013-03-14 | Z2.2300 FF+40d, 1.3.4.3.030 |  |  |  |  | -80.38d | 102.12d | SSH-Construction Manhours [2292 h] | 134,818 |
| Z2.2320 |  | Install valves | 30d | 2013-03-09 | 2013-04-06 | Z2.2264, 1.3.4.2.030, Z2.2260 |  |  |  |  | -104.8d | 77.7d | SSH-Construction Manhours [2122 h] | 175,000 |

| ID | WBS | Activity | Duration | Start | Finish | Predecessors | Complete | Remaining | Planned start | Planned finish | Total float | Free float | Resources | Cost |
| --- | --- | --- | --- | --- | --- | --- | --- | --- | --- | --- | --- | --- | --- | --- |
|  | 4 | **Zone 4** |  | 2012-05-15 | 2013-05-27 |  |  |  |  |  |  |  |  |  |
|  | 1 | **A4** |  | 2012-05-15 | 2013-05-27 |  |  |  |  |  |  |  |  |  |
| Z4.1110 |  | Excavation for water lineA | 25d | 2012-05-15 A | 2013-02-02 | Z4.1040 FF, M2.05 |  | 25d | 2012-05-15 | 2012-06-06 | -160d | 0d | SSH-Construction Manhours [424 h]; Excavator [100 h]; Dump Truck [100 h] | 4,800 |
| Z4.1120 |  | Construction of valve boxes (3) | 60d | 2013-02-03 | 2013-03-30 | Z4.1110 |  |  |  |  | -160d | 0d | SSH-Construction Manhours [2097 h] | 39,648 |
| Z4.1130 |  | Install PW/FW/CTMU line(180LM)A | 12.5d | 2013-03-31 | 2013-04-10 | Z4.1120 |  |  |  |  | -160d | 0d | SSH-Construction Manhours [594 h] | 57,800 |
| Z4.1170 |  | Install valves | 18.75d | 2013-03-31 | 2013-04-16 | Z4.1120, 1.3.4.2.030 |  |  |  |  | -116.25d | 66.25d | SSH-Construction Manhours [1265 h] | 75,000 |
| Z4.1140 |  | Excavation for water lineB | 18.75d | 2013-04-11 | 2013-04-28 | Z4.1130 |  |  |  |  | -160d | 0d | SSH-Construction Manhours [509 h] | 4,800 |
| Z4.1160 |  | Install fire hydrants | 37.5d | 2013-04-23 | 2013-05-27 | Z4.1150 FF, 1.3.4.3.030 |  |  |  |  | -160d | 22.5d | SSH-Construction Manhours [1257 h] | 50,000 |
| Z4.1150 |  | Install PW/FW/CTMU line(495LM)B | 31.25d | 2013-04-29 | 2013-05-27 | Z4.1140 |  |  |  |  | -160d | 0d | SSH-Construction Manhours [1486 h] | 57,800 |
|  | 2 | **Sewer Sanitary System** |  | 2011-07-24 | 2013-06-05 |  |  |  |  |  |  |  |  |  |
|  | 1 | **Zone 3** |  | 2011-08-07 | 2012-12-24 |  |  |  |  |  |  |  |  |  |
|  | 1 | **A3-1** |  | 2011-08-16 | 2012-12-17 |  |  |  |  |  |  |  |  |  |
| Z3.1180 |  | Excavation for sewer trench SMH02RA-SMH08RA+Dewatering | 12.5d | 2011-08-16 A | 2011-08-28 A | M2.04 FF | 100% |  | 2011-08-16 | 2011-08-27 |  |  | SSH-Construction Manhours [1407 h]; Excavator [100 h]; Dump Truck [100 h] | 192,667 |
| Z3.1030 |  | Excavation for gravity trench SMH19R3-SMH11R3+Dewatering | 22.5d | 2011-09-07 A | 2011-09-27 A | M2.04 FF | 100% |  |  |  |  |  | SSH-Construction Manhours [1089 h]; Excavator [180 h]; Dump Truck [180 h] | 192,677 |
| Z3.1212 |  | Install sewer manholes (3) | 31.25d | 2011-10-10 A | 2012-10-07 | Z3.1211 SS | 90% | 3.12d | 2011-10-10 | 2011-11-07 | 25.75d | 0d | SSH-Construction Manhours [2111 h] | 34,994 |
| Z3.1211 |  | Excavation for sewer trench SMH06RA- SMH08RA | 10d | 2011-10-15 A | 2011-10-24 A | Z3.1180 SS | 100% |  | 2011-10-15 | 2011-10-23 |  |  | SSH-Construction Manhours [1407 h] | 192,667 |
| Z3.1050 |  | Installation of sewer pipe (750LM) | 25d | 2011-10-27 A | 2012-10-06 | Z3.1030 SS, 1.3.4.6.030 SS | 90% | 2.5d | 2011-10-27 | 2011-11-19 | 33.71d | 0d | SSH-Construction Manhours [6040 h] | 56,383 |
| Z3.1214 |  | Excavation for sewer trench SMH01RP- SMH07RP | 18.75d | 2011-11-04 A | 2011-12-20 A | Z3.1213 SS | 100% |  | 2011-12-04 | 2011-12-20 |  |  | SSH-Construction Manhours [1811 h] | 192,667 |
| Z3.1040 |  | Installation of Sewer Manholes SMH19R3-SMH11R3(9) | 31.25d | 2011-11-10 A | 2012-10-07 | Z3.1050 SS | 90% | 3.12d | 2011-11-10 | 2011-12-08 | 33.71d | 0d | SSH-Construction Manhours [7551 h] | 34,994 |
| Z3.1215 |  | Install sewer manholes (7) | 31.25d | 2011-11-10 A | 2012-10-07 | Z3.1214 SS | 90% | 3.12d | 2011-11-10 | 2011-12-08 | 25.75d | 0d | SSH-Construction Manhours [4430 h] | 34,994 |
| Z3.1213 |  | Install sewer pipe line (210LM) | 12.5d | 2011-11-22 A | 2012-10-04 | Z3.1212 SS | 90% | 1.25d | 2011-11-22 | 2011-12-03 | 25.75d | 0d | SSH-Construction Manhours [1004 h] | 56,382 |
| Z3.1216 |  | Install sewer pipeline (575LM) | 30d | 2012-01-19 A | 2012-10-04 | Z3.1215 SS | 97% | 0.9d | 2012-01-19 | 2012-02-15 | 28.75d | 0d | SSH-Construction Manhours [2417 h] | 56,382 |
| Z3.1190 |  | Installation of Sewer Manholes 01 - 07 (7) | 31.25d | 2012-01-21 A | 2012-10-07 | Z3.1180 SS | 90% | 3.12d | 2012-01-21 | 2012-02-18 | 40.06d | 1.88d | SSH-Construction Manhours [5030 h] | 34,994 |
| Z3.1210 |  | Installation of sewer pipe (560LM) | 20d | 2012-02-26 A | 2012-10-08 | Z3.1211 SS | 75% | 5d | 2012-02-26 | 2012-03-15 | 38.19d | 0d | SSH-Construction Manhours [3219 h] | 56,382 |
| Z3.1051 |  | Install sewer manhoels SMH11R2-SMH08R4 (03) | 60d | 2012-03-03 A | 2012-10-13 | Z3.1040 | 90% | 6d | 2012-03-03 | 2012-04-26 | 33.71d | 0d | SSH-Construction Manhours [2515 h] | 35,144 |
| Z3.1052 |  | Install sewer pipe (325LM) | 25d | 2012-04-28 A | 2012-10-17 | Z3.1051 | 80% | 5d | 2012-04-28 | 2012-05-20 | 33.71d | 0d | SSH-Construction Manhours [2619 h] | 56,382 |
| Z3.1100 |  | Excavation for sewer trench SMH11R3-LS10+Dewatering | 6.25d | 2012-04-28 A | 2012-05-02 A | Z3.1040, Z3.1051 | 100% |  |  |  |  |  | SSH-Construction Manhours [704 h]; Excavator [50 h]; Dump Truck [50 h] | 192,667 |
| Z3.1110 |  | Installation of Sewer Manholes SMH11R3-LS10 (5) | 25d | 2012-05-03 A | 2012-10-15 | Z3.1100 | 90% | 2.5d | 2012-05-03 | 2012-05-26 | 35.88d | 0d | SSH-Construction Manhours [6040 h] | 34,994 |
| Z3.1060 |  | Partial Backfilling | 7.5d | 2012-05-21 A | 2012-10-21 | Z3.1052 | 42% | 4.35d | 2012-05-21 | 2012-05-27 | 33.71d | 60.73d | SSH-Construction Manhours [844 h]; Dump Truck [60 h] | 229,787 |
| Z3.1120 |  | Installation of Sewer Pipe (225LM) | 15d | 2012-05-27 A | 2012-10-16 | Z3.1110 | 90% | 1.5d | 2012-05-27 | 2012-06-09 | 35.88d | 58.36d | SSH-Construction Manhours [3623 h] | 56,382 |
| Z3.1130 |  | Installation of Sewer Manholes SMHRL1-SMH07RP (4) | 60d | 2012-06-10 A | 2012-12-15 | Z3.1120, M2.08 | 90% | 6d | 2012-06-10 | 2012-08-04 | -22.49d | 0d | SSH-Construction Manhours [5134 h] | 34,994 |
| Z3.1140 |  | Installation of Sewer Pipe SMHRL1-SMH07RP (290LM) | 12.5d | 2012-08-05 A | 2012-12-17 | Z3.1130 | 80% | 2.5d | 2012-08-05 | 2012-08-15 | -22.49d | 0d | SSH-Construction Manhours [2013 h] | 56,382 |
| Z3.1220 |  | Partial Backfilling | 25d | 2012-08-16 A | 2012-09-08 A | Z3.1216 SS | 100% |  |  |  |  |  | SSH-Construction Manhours [844 h]; Dump Truck [60 h] | 229,787 |

| ID | WBS | Activity | Duration | Start | Finish | Predecessors | Complete | Remaining | Planned start | Planned finish | Total float | Free float | Resources | Cost |
| --- | --- | --- | --- | --- | --- | --- | --- | --- | --- | --- | --- | --- | --- | --- |
|  | 2 | **A3-2** |  | 2011-08-07 | 2012-12-19 |  |  |  |  |  |  |  |  |  |
| Z3.2080 |  | Installation of sewer pipe SMH01R2-SMH28RA (300LM) | 27.5d | 2011-08-07 A | 2012-10-08 | Z3.1215 SS | 85% | 4.12d | 2011-08-07 | 2011-08-31 | 57d | 0d | SSH-Construction Manhours [7973 h] | 98,670 |
| Z3.2110 |  | Excavation for sanitary trench SMH01R3-LS11 | 18.75d | 2011-10-01 A | 2011-10-17 A | Z3.2080 SS | 100% |  |  |  |  |  | SSH-Construction Manhours [2111 h]; Excavator [150 h]; Dump Truck [150 h] | 321,113 |
| Z3.2120 |  | Installation of sewer pipe SMH01R3-LS11(327LM) | 31.25d | 2011-10-18 A | 2012-10-06 | Z3.2110 SS | 92% | 2.34d | 2011-10-18 | 2011-11-15 | 57.66d | 5.47d | SSH-Construction Manhours [7551 h] | 98,670 |
| Z3.2051 |  | Excavation for sanitary trench SMH05R3-SMH01R | 15d | 2011-11-02 A | 2011-11-15 A | Z3.1215 SS | 100% |  |  |  |  |  | SSH-Construction Manhours [1609 h] | 107,037 |
| Z3.2140 |  | Installation of Manholes SMHRL16 -LS11 (7) | 26.25d | 2011-11-10 A | 2012-10-06 | Z3.2130 SS | 95% | 1.31d | 2011-11-10 | 2011-12-04 | 58.31d | 0d | SSH-Construction Manhours [4228 h] | 61,277 |
| Z3.2130 |  | Excavation of sanitary trench SMHRL16 -LS11 | 12.5d | 2011-11-16 A | 2011-11-27 A | Z3.1215 SS | 100% |  |  |  |  |  | SSH-Construction Manhours [1407 h]; Excavator [100 h]; Dump Truck [100 h] | 321,113 |
| Z3.2060 |  | Installation of sewer pipe SMH05R3 -SMH01R3 (360LM) | 27.5d | 2011-12-10 A | 2012-10-06 | Z3.2051 SS | 95% | 1.38d | 2011-12-10 | 2012-01-03 | 25.75d | 0d | SSH-Construction Manhours [6646 h] | 98,670 |
| Z3.2150 |  | Installation of sewer pipe SMHRL16 -LS11 (730LM) | 22.5d | 2011-12-22 A | 2012-10-06 | Z3.2140 SS | 92% | 1.69d | 2011-12-22 | 2012-01-11 | 58.31d | 6.12d | SSH-Construction Manhours [5434 h] | 98,670 |
| Z3.2075 |  | Installation of Manholes SMH01R2-SMH28RA(5) | 60d | 2012-01-28 A | 2012-10-07 | Z3.2060 SS | 95% | 3d | 2012-01-28 | 2012-03-22 | 25.75d | 65.06d | SSH-Construction Manhours [2821 h] | 61,277 |
| Z3.2090 |  | Installation of Manholes SMHRL16 -SMH28RA (7) | 60d | 2012-01-29 A | 2012-10-07 | Z3.2080 SS | 95% | 3d | 2012-01-29 | 2012-03-24 | 57d | 4.81d | SSH-Construction Manhours [5030 h] | 61,277 |
| Z3.2065 |  | Installation of Manholes SMH01R3 -SMH28RA (5) | 60d | 2012-01-30 A | 2012-10-07 | Z3.2060 SS | 95% | 3d | 2012-01-30 | 2012-03-25 | 57.94d | 0d | SSH-Construction Manhours [4027 h] | 61,277 |
| Z3.2066 |  | Excavation of sewer trench SMH01R3-SMH28RA | 15d | 2012-02-01 A | 2012-02-14 A | Z3.2065 SS | 100% |  |  |  |  |  | SSH-Construction Manhours [2013 h] | 107,038 |
| Z3.2070 |  | Installation of sewer pipe SMH01R3 -SMH28RA (380LM) | 27.5d | 2012-02-18 A | 2012-10-06 | Z3.2066 | 92% | 2.06d | 2012-02-18 | 2012-03-14 | 57.94d | 5.75d | SSH-Construction Manhours [6646 h] | 98,670 |
| Z3.2040 |  | Excavation for sanitary trench SMH06R3 -SMH05R4 | 25d | 2012-05-16 A | 2012-06-07 A | Z3.2030, 1.2.6.200, Z3.1190, Z3.1210 | 100% |  |  |  |  |  | SSH-Construction Manhours [2821 h]; Excavator [200 h]; Dump Truck [200 h] | 107,037 |
| Z3.2045 |  | Installation of Manholes SMH06R3 -SMH05R4 (5) | 60d | 2012-06-09 A | 2012-10-17 | Z3.2040 | 85% | 9d | 2012-06-09 | 2012-08-02 | 38.19d | 0d | SSH-Construction Manhours [4027 h] | 61,277 |
| Z3.2050 |  | Installation of sewer pipe SMH06R3 -SMH05R4 (400LM) | 31.25d | 2012-08-04 A | 2012-10-22 | Z3.2045 | 83% | 5.31d | 2012-08-04 | 2012-09-01 | 38.19d | 60.68d | SSH-Construction Manhours [7551 h] | 98,670 |
| Z3.2055 |  | Installation of Manholes SMH05R3 -SMH01R3 (5) | 50d | 2012-09-02 A | 2012-12-19 | Z3.2050, Z3.1140 | 95% | 2.5d | 2012-09-02 | 2012-10-17 | -22.49d | 180.01d | SSH-Construction Manhours [4027 h] | 61,277 |
|  | 3 | **A3-3** |  | 2011-09-01 | 2012-10-21 |  |  |  |  |  |  |  |  |  |
| Z3.3110 |  | Excavation for sewer line SMH13RA-SMH09RA | 18.75d | 2011-09-01 A | 2011-12-12 A | Z3.3020 SS | 100% |  | 2011-08-24 | 2011-09-10 |  |  | SSH-Construction Manhours [2120 h]; Excavator [150 h]; Dump Truck [150 h] | 321,113 |
| Z3.3120 |  | Instalaltion of sewer Manholes SMH13RA-SMH09RA (5) | 31.25d | 2011-09-03 A | 2012-10-08 | M2.04 FF | 88% | 3.91d | 2011-09-03 | 2011-10-01 | 11.09d | 0d | SSH-Construction Manhours [5030 h] | 61,277 |
| Z3.3130 |  | Instalaltion of sewer line SMH13RA-SMH09RA (285LM) | 18.75d | 2011-09-13 A | 2012-10-06 | 1.3.4.5.030 SS, Z3.3110 FF | 90% | 1.88d | 2011-10-10 | 2011-10-26 | 54.22d | 2.03d | SSH-Construction Manhours [4528 h] | 98,670 |
| Z3.3140 |  | Excavation for sewer line SMH09RA-SMH11R2 | 12.5d | 2011-10-27 A | 2011-11-07 A | M2.04 FF, Z3.3120 FF | 100% |  |  |  |  |  | SSH-Construction Manhours [1407 h]; Excavator [100 h]; Dump Truck [100 h] | 321,113 |
| Z3.3170 |  | Excavation for sewer line SMH13RA - SMH01R2 | 25d | 2011-12-11 A | 2012-01-02 A | Z3.3140 SS | 100% |  |  |  |  |  | SSH-Construction Manhours [2821 h]; Excavator [200 h]; Dump Truck [200 h] | 321,113 |
| Z3.3180 |  | Installaiton of manholes SMH13RA - SMH01R2 (7) | 31.25d | 2011-12-17 A | 2012-10-11 | Z3.3170 SS | 88% | 3.91d | 2011-12-17 | 2012-01-14 | 52.19d | 0d | SSH-Construction Manhours [7551 h] | 61,277 |
| Z3.3190 |  | Installation of sewer line SMH13RA - SMH01R2 (598LM) | 31.25d | 2012-02-01 A | 2012-10-11 | Z3.3180 SS | 88% | 3.75d | 2012-02-01 | 2012-02-29 | 52.19d | 0d | SSH-Construction Manhours [10066 h] | 98,670 |
| Z3.3210 |  | Installation of sewer manholes SM10R2 - SM02R2 (9) | 31.25d | 2012-02-20 A | 2012-10-11 | Z3.3200, Z3.3130 | 88% | 3.91d | 2012-02-20 | 2012-03-20 | 52.19d | 0d | SSH-Construction Manhours [3525 h] | 61,277 |
| Z3.3150 |  | Installation of sewer manhole SMH09RA-SMH11R2 (3) | 60d | 2012-02-25 A | 2012-10-15 | Z3.3140 | 88% | 7.5d | 2012-02-25 | 2012-04-21 | 11.09d | 0d | SSH-Construction Manhours [3017 h] | 61,277 |
| Z3.3200 |  | Excavation for sewer line SM10R2 - SM02R2 | 25d | 2012-03-01 A | 2012-03-24 A | Z3.3190 SS | 100% |  |  |  |  |  | SSH-Construction Manhours [2821 h]; Excavator [200 h]; Dump Truck [200 h] | 321,113 |
| Z3.3220 |  | Installation of sewer line SM10R2 - SM02R2 (780)A | 31.25d | 2012-03-20 A | 2012-04-18 A | Z3.3210, Z3.2070 | 100% |  |  |  |  |  | SSH-Construction Manhours [3525 h] | 98,670 |
| Z3.3230 |  | Installation of sewer line SM10R2 - SM02R2 (780)B | 31.25d | 2012-04-18 A | 2012-05-17 A | Z3.3220, Z3.2090, Z3.2120, Z3.2150 | 100% |  |  |  |  |  | SSH-Construction Manhours [3525 h] | 98,670 |
| Z3.3160 |  | Installaiton of sewer line SMH09RA-SMH11R2 (270LM) | 25d | 2012-04-21 A | 2012-10-21 | Z3.3150 | 75% | 6.25d | 2012-04-21 | 2012-05-14 | 11.09d | 50.41d | SSH-Construction Manhours [3922 h] | 98,670 |

| ID | WBS | Activity | Duration | Start | Finish | Predecessors | Complete | Remaining | Planned start | Planned finish | Total float | Free float | Resources | Cost |
| --- | --- | --- | --- | --- | --- | --- | --- | --- | --- | --- | --- | --- | --- | --- |
|  | 5 | **A3-5** |  | 2012-05-31 | 2012-12-24 |  |  |  |  |  |  |  |  |  |
| Z3.5030 |  | Excvation for sewer line SMH10R3-SMH01R4 | 18.75d | 2012-05-31 A | 2012-06-18 A | Z3.5020, Z3.4030 | 100% |  |  |  |  |  | SSH-Construction Manhours [1206 h]; Excavator [150 h]; Dump Truck [150 h] | 321,113 |
| Z3.5040 |  | Installation of sewer manholes SMH10R3-SMH01R4(5) | 60d | 2012-06-18 A | 2012-12-17 | Z3.5030 | 85% | 9d | 2012-06-18 | 2012-08-13 | -27.01d | 0d | SSH-Construction Manhours [4027 h] | 61,277 |
| Z3.5050 |  | Installation of sewer line SMH10R3-SMH01R4 (350LM) | 31.25d | 2012-08-13 A | 2012-12-24 | Z3.5040, Z3.1060 | 75% | 7.81d | 2012-08-13 | 2012-09-11 | -27.01d | 175.49d | SSH-Construction Manhours [7554 h] | 98,674 |
|  | 2 | **Zone 2** |  | 2011-07-24 | 2013-01-05 |  |  |  |  |  |  |  |  |  |
|  | 1 | **A2-1** |  | 2011-08-22 | 2012-10-13 |  |  |  |  |  |  |  |  |  |
| Z2.1030 |  | Excavation for sewer line SMH01RC-SMH04R7 | 18.75d | 2011-08-22 A | 2012-10-06 | M2.04 FF | 90% | 1.88d | 2011-08-22 | 2011-09-07 | -182.11d | 0d | SSH-Construction Manhours [2111 h]; Excavator [150 h]; Dump Truck [150 h] | 156,000 |
| Z2.1050 |  | Install sewer line SMH01RC-SMH04R7 (350LM) | 31.25d | 2011-10-03 A | 2012-10-13 | Z2.1030 FF | 69% | 9.76d | 2011-10-03 | 2011-10-31 | -190d | 0d | SSH-Construction Manhours [7551 h] | 77,284 |
| Z2.1040 |  | Install sewer manholes SMH01RC-SMH04R7 (5) | 60d | 2012-02-26 A | 2012-10-13 | Z2.1030 | 88% | 7.5d | 2012-02-26 | 2012-04-22 | 44.02d | 36.02d | SSH-Construction Manhours [4228 h] | 76,974 |
|  | 2 | **A2-2** |  | 2011-07-24 | 2013-01-05 |  |  |  |  |  |  |  |  |  |
| Z2.2120 |  | Excavation for sewer trench SMH01R7-SMH04R7 | 18.75d | 2011-07-24 A | 2011-08-09 A | Z2.2060 SS | 100% |  |  |  |  |  | SSH-Construction Manhours [2111 h]; Dump Truck [150 h]; Excavator [150 h] | 156,000 |
| Z2.2140 |  | Install sewer line SMH01R7-SMH04R7 (330LM) | 18.75d | 2011-09-03 A | 2012-10-08 | Z2.2120 SS | 78% | 4.12d | 2011-09-03 | 2011-09-19 | -39.31d | 0d | SSH-Construction Manhours [4528 h] | 77,276 |
| Z2.2030 |  | Excavation for sewer trench SMH05R7 - SMH18RC | 18.75d | 2011-09-08 A | 2012-10-04 | Z2.1050 SS | 98% | 0.47d | 2011-09-08 | 2011-09-25 | -190d | 0d | SSH-Construction Manhours [2111 h]; Excavator [150 h]; Dump Truck [150 h] | 156,000 |
| Z2.2150 |  | Excavation for sewer trench SMH04R7-SMH12RC | 25d | 2011-09-20 A | 2012-10-06 | Z2.2140 SS | 90% | 2.5d | 2011-09-20 | 2011-10-12 | -39.31d | 0d | SSH-Construction Manhours [2811 h]; Dump Truck [200 h]; Excavator [200 h] | 156,000 |
| Z2.2050 |  | Install sewer line SMH05R7 - SMH18RC (406LM) | 25d | 2011-10-25 A | 2012-10-08 | Z2.2030 SS | 83% | 4.22d | 2011-10-25 | 2011-11-16 | -39.31d | 0d | SSH-Construction Manhours [6040 h] | 77,276 |
| Z2.2170 |  | Installation of sewer line SMH04R7-SMH12RC (652LM)A | 18.75d | 2011-11-12 A | 2012-10-07 | Z2.2180 SS | 80% | 3.75d | 2011-11-12 | 2011-11-28 | 25d | 64.31d | SSH-Construction Manhours [4528 h] | 77,276 |
| Z2.2060 |  | Excavation for sewer line SMH13R7-SMH17RC | 18.75d | 2011-11-17 A | 2011-12-04 A | Z2.2050 SS | 100% |  |  |  |  |  | SSH-Construction Manhours [2111 h]; Dump Truck [150 h]; Excavator [150 h] | 156,000 |
| Z2.2180 |  | Installation of sewer line SMH04R7-SMH12RC (652LM)B | 18.75d | 2011-11-29 A | 2012-10-13 | Z2.2150 SS | 49% | 9.56d | 2011-11-29 | 2011-12-15 | -39.31d | 0d | SSH-Construction Manhours [4528 h] | 77,276 |
| Z2.2130 |  | Install sewer manholes SMH01R7-SMH04R7 (5) | 50d | 2012-02-18 A | 2012-10-10 | Z2.2120, Z2.2140 SS | 85% | 7.5d | 2012-02-18 | 2012-04-04 | 21.25d | 60.56d | SSH-Construction Manhours [4027 h] | 76,974 |
| Z2.2040 |  | Install sewer manholes SMH05R7 - SMH18RC (6) | 60d | 2012-02-27 A | 2012-10-11 | Z2.2030 | 88% | 7.5d | 2012-02-27 | 2012-04-23 | 45.43d | 37.43d | SSH-Construction Manhours [5030 h] | 76,974 |
| Z2.2070 |  | Install sewer line manhole SMH13R7-SMH17RC (5) | 40d | 2012-02-29 A | 2012-10-23 | Z2.2060 | 47% | 21.2d | 2012-02-29 | 2012-04-07 | 8d | 0d | SSH-Construction Manhours [4027 h] | 76,974 |
| Z2.2190 |  | Excavation for sewer line SMH02AR7-interface point-A | 50d | 2012-03-01 A | 2012-11-08 | Z2.2180 | 42% | 29d | 2012-03-01 | 2012-04-17 | -39.31d | 0d | SSH-Construction Manhours [2111 h]; Dump Truck [150 h]; Excavator [150 h] | 156,000 |
| Z2.2160 |  | Installation of manhoels SMH04R7-SMH12RC (11) | 50d | 2012-03-06 A | 2012-10-13 | Z2.2150 | 85% | 7.5d | 2012-03-06 | 2012-04-21 | 18.75d | 58.06d | SSH-Construction Manhours [5030 h] | 76,974 |
| Z2.2080 |  | Install sewer line SMH13R7-SMH17RC (294LM) | 40d | 2012-04-07 A | 2012-11-11 | Z2.2070 | 52% | 19d | 2012-04-07 | 2012-05-14 | 8d | 0d | SSH-Construction Manhours [4528 h] | 77,276 |
| Z2.2200 |  | Instal F.sewer line SMH02AR7-interface point (29040LM)A | 50d | 2012-04-17 A | 2012-06-03 A | Z2.2190 | 100% |  |  |  |  |  | SSH-Construction Manhours [6040 h] | 77,276 |
| Z2.2202 |  | Excavation for sewer line SMH02AR7-interface point-B | 18.75d | 2012-05-05 A | 2012-11-21 | Z2.2200 SS+18.75d | 31% | 12.94d | 2012-05-05 | 2012-05-22 | -39.31d | 0d | SSH-Construction Manhours [1206 h]; Dump Truck [150 h]; Excavator [150 h] | 156,000 |
| Z2.2090 |  | Excavation for sewer line SMH17RC-SMH12RC | 40d | 2012-05-14 A | 2012-06-20 A | Z2.2080 | 100% |  |  |  |  |  | SSH-Construction Manhours [2111 h]; Dump Truck [150 h]; Excavator [150 h] | 156,000 |
| Z2.2210 |  | Instal F.sewer line SMH02AR7-interface point (2940LM)B | 50d | 2012-05-16 A | 2012-12-23 | Z2.2202 SS+12.5d | 6% | 46.9d | 2012-05-16 | 2012-07-02 | -39.31d | 0d | SSH-Construction Manhours [2821 h] | 77,276 |
| Z2.2212 |  | Excavation for sewer line SMH02AR7-interface point-C | 18.75d | 2012-06-03 A | 2012-11-19 | Z2.2210 SS+18.75d | 43% | 10.69d | 2012-06-03 | 2012-06-20 | -39.31d | 0d | SSH-Construction Manhours [1206 h]; Dump Truck [150 h]; Excavator [150 h] | 156,000 |
| Z2.2220 |  | Instal F.sewer line SMH02AR7-interface point (2940LM)C | 50d | 2012-06-14 A | 2012-12-06 | Z2.2212 SS+12.5d | 41% | 29.5d | 2012-06-14 | 2012-07-31 | -39.31d | 0d | SSH-Construction Manhours [6040 h] | 77,276 |
| Z2.2100 |  | Install sewer manholes SMH17RC-SMH12RC (7) | 40d | 2012-06-20 A | 2012-11-15 | Z2.2090 | 87% | 5.2d | 2012-06-20 | 2012-07-28 | 8d | 0d | SSH-Construction Manhours [3525 h] | 76,974 |
| Z2.2110 |  | Install sewer line SMH17RC-SMH12RC (410LM) | 40d | 2012-07-28 A | 2012-11-21 | Z2.2100, Z2.1040, Z2.2040 | 84% | 6.6d | 2012-07-28 | 2012-09-03 | 8d | 47.31d | SSH-Construction Manhours [6040 h] | 77,276 |
| Z2.2340 |  | Backfilling | 31.25d | 2012-12-06 | 2013-01-05 | Z2.2220, Z2.2110 FF, Z2.2130, Z2.2160, Z2.2170, Z3.1220, Z3.2075, Z3.3160 |  |  |  |  | -39.31d | 32.19d | SSH-Construction Manhours [3525 h] | 230,922 |

| ID | WBS | Activity | Duration | Start | Finish | Predecessors | Complete | Remaining | Planned start | Planned finish | Total float | Free float | Resources | Cost | QTY |
| --- | --- | --- | --- | --- | --- | --- | --- | --- | --- | --- | --- | --- | --- | --- | --- |
|  | 3 | **Zone 4** |  | 2012-04-17 | 2013-02-04 |  |  |  |  |  |  |  |  |  |  |
|  | 1 | **A4** |  | 2012-04-17 | 2013-02-04 |  |  |  |  |  |  |  |  |  |  |
| Z4.1030 |  | Excavation for sewer line SMH18R2-SMH29R3+Dewatering | 35d | 2012-04-17 A | 2012-10-20 | Z2.2230 SS | 50% | 17.5d | 2012-04-17 | 2012-05-19 | -71.5d | 0d | SSH-Construction Manhours [2821 h]; Excavator [200 h]; Dump Truck [200 h] | 364,267 |  |
| Z4.1040 |  | Install sewer manholes SMH18R2-SMH29R3 (7) | 35d | 2012-05-06 A | 2012-11-07 | Z4.1030 FF+20d | 45% | 19.25d | 2012-05-06 | 2012-06-06 | -71.5d | 0d | SSH-Construction Manhours [5030 h] | 141,162 |  |
| Z4.1050 |  | Install sewer line SMH18R2-SMH29R3 (405LM) | 35d | 2012-05-24 A | 2012-11-26 | Z4.1040 FF+20d | 55% | 15.75d | 2012-05-24 | 2012-06-25 | -71.5d | 0d | SSH-Construction Manhours [6040 h] | 161,162 |  |
| Z4.1060 |  | Excavation for sewer line SMH20R3-SMH29R3 | 20d | 2012-06-26 A | 2012-07-14 A | Z4.1050 | 100% |  |  |  |  |  | SSH-Construction Manhours [2013 h] | 364,267 |  |
| Z4.1070 |  | Install sewer manholes SMH20R3-SMH29R3 (7) | 35d | 2012-07-10 A | 2012-11-26 | Z4.1060 FF+30d | 60% | 14d | 2012-07-10 | 2012-08-11 | -71.5d | 0d | SSH-Construction Manhours [4027 h] | 141,162 |  |
| Z4.1080 |  | Install sewr line SMH20R3-SMH29R3 (630LM) | 35d | 2012-08-02 A | 2012-12-19 | Z4.1070 FF+25d | 77% | 8.05d | 2012-08-02 | 2012-09-03 | -71.5d | 0d | SSH-Construction Manhours [7551 h] | 161,162 |  |
| Z4.1090 |  | Excvation for sewer line SMH20R3- SD CHAMBER | 20d | 2012-09-09 A | 2013-01-12 | Z4.1080 FF+25d | 83% | 3.4d | 2012-09-09 | 2012-09-26 | -71.5d | 0d | SSH-Construction Manhours [2013 h]; Excavator [200 h]; Dump Truck [200 h] | 364,267 |  |
| Z4.1100 |  | Install sewer line SMH20R3- SD CHAMBER | 35d | 2012-09-13 A | 2013-01-30 | Z4.1090 FF+20d | 33% | 23.45d | 2012-09-13 | 2012-10-15 | -71.5d | 0d | SSH-Construction Manhours [3525 h] | 161,162 |  |
| Z4.1180 |  | Backfilling | 35d | 2013-01-02 | 2013-02-04 | Z4.1100 FF+4d, Z2.2340 FF |  |  |  |  | -71.5d | 131d | SSH-Construction Manhours [2515 h] | 141,159 |  |
|  | 4 | **Lift Station Buildings** |  | 2011-09-13 | 2013-06-05 |  |  |  |  |  |  |  |  |  |  |
|  | 1 | **LS 9 Building - Zone 4** |  | 2012-03-22 | 2013-04-15 |  |  |  |  |  |  |  |  |  |  |
| 1.4.2.3.5.010 |  | Excavation leveling & compaction for LS9 | 25d | 2012-03-22 A | 2012-10-21 | 1.4.2.3.6.030 SS+6d | 25% | 18.75d | 2012-03-22 | 2012-04-15 | -147.5d | 0d | SSH-Construction Manhours [703.06 h]; Excavator [100 h]; Dump Truck [100 h] | 15,000 |  |
| 1.4.2.3.5.025 |  | Install Base slab for LS9 | 31.25d | 2012-10-21 | 2012-11-18 | 1.4.2.3.5.020 FF+10d |  |  |  |  | -147.5d | 0d | SSH-Construction Manhours [1115.97 h] | 20,000 |  |
| 1.4.2.3.5.020 |  | Install lean concrete & water proofing works LS9 | 18.75d | 2012-10-23 | 2012-11-08 | 1.4.2.3.5.010 FF+20d |  |  |  |  | -147.5d | 0d | SSH-Construction Manhours [862.09 h] | 32,500 |  |
| 1.4.2.3.5.030 |  | Construction for retaining walls LS9 | 18.75d | 2012-11-19 | 2012-12-05 | 1.4.2.3.5.010 SS+12.5d, M1.10, M1.12, 1.4.2.3.5.025 |  |  |  |  | -147.5d | 0d | SSH-Construction Manhours [1673.96 h] | 4,000 |  |
| 1.4.2.3.5.040 |  | Constrcution for sump pit LS9 | 25d | 2012-11-22 | 2012-12-15 | 1.4.2.3.5.030 SS+3.75d |  |  |  |  | -147.5d | 0d | SSH-Construction Manhours [3905.91 h] | 47,000 |  |
| 1.4.2.3.5.050 |  | Construction for top slab LS9 | 31.25d | 2012-12-16 | 2013-01-13 | 1.4.2.3.5.040 |  |  |  |  | -147.5d | 0d | SSH-Construction Manhours [3905.91 h] | 82,250 |  |
| 1.4.2.3.5.060 |  | Construction of wall with water proofing LS9 | 18.75d | 2013-01-08 | 2013-01-24 | 1.4.2.3.5.050 SS+25d |  |  |  |  | -147.5d | 0d | SSH-Construction Manhours [3905.91 h] | 38,750 |  |
| 1.4.2.3.5.070 |  | Backfilling & Compaction LS9 | 25d | 2013-01-12 | 2013-02-03 | 1.4.2.3.5.060 FF+10d |  |  |  |  | -147.5d | 0d | SSH-Construction Manhours [1149.45 h] | 47,000 |  |
| 1.4.2.3.5.080 |  | Plastering & Painting work LS9 -Door installation | 31.25d | 2013-02-04 | 2013-03-04 | 1.4.2.3.5.070, 1.4.2.3.5.020 SS |  |  |  |  | -147.5d | 0d | SSH-Construction Manhours [958.06 h]; Dump Truck [160 h] | 11,250 |  |
| 1.4.2.3.5.130 |  | Install precast concrete fence & gate LS9 | 30d | 2013-02-10 | 2013-03-09 | 1.4.2.3.5.080 FF+5d |  |  |  |  | -147.5d | 0d | SSH-Construction Manhours [919.01 h] | 200,000 |  |
| 1.4.2.3.5.140 |  | Install asphalt pavement LS9 | 30d | 2013-02-19 | 2013-03-18 | 1.4.2.3.5.130 SS+10d |  |  |  |  | -147.5d | 0d | SSH-Construction Manhours [3386.98 h] | 22,650 |  |
| 1.4.2.3.5.150 |  | Install piping System & odour control system | 30d | 2013-02-19 | 2013-03-18 | 1.4.2.3.5.140 FF, 1.3.4.9.030, 1.3.4.10.030 |  |  |  |  | -147.5d | 0d | SSH-Construction Manhours [1149.45 h]; Welding Machine [240 h] | 11,000 |  |
| 1.4.2.3.5.151 |  | Install Instruments & Local control panel & accs | 30d | 2013-02-19 | 2013-03-18 | 1.4.2.3.5.150 FF |  |  |  |  | -147.5d | 0d | SSH-Construction Manhours [1115.97 h] | 38,500 |  |
| 1.4.2.3.5.152 |  | Install odour control system cabling and instruments | 30d | 2013-02-19 | 2013-03-18 | 1.4.2.3.5.151 FF |  |  |  |  | -147.5d | 0d | SSH-Construction Manhours [1115.97 h] | 38,500 |  |
| 1.4.2.3.5.155 |  | Install electrical/instr work / fire alarm system in LS9 | 30d | 2013-02-19 | 2013-03-18 | 1.4.2.3.5.150 FF |  |  |  |  | -147.5d | 0d | SSH-Construction Manhours [1149.45 h] | 11,000 | 0.003249364 |
| 1.4.2.3.5.160 |  | Testing & Commissioning of LS 9 | 30d | 2013-03-19 | 2013-04-15 | 1.4.2.3.5.155, 1.4.3.1.1.570, 1.4.3.1.2.570, M2.10, 1.4.2.7.4.126, 1.4.2.3.5.152 |  |  |  |  | -147.5d | 55d | SSH-Construction Manhours [658.43 h] | 10,000 |  |

| ID | WBS | Activity | Duration | Start | Finish | Predecessors | Complete | Remaining | Planned start | Planned finish | Total float | Free float | Resources | Cost | QTY |
| --- | --- | --- | --- | --- | --- | --- | --- | --- | --- | --- | --- | --- | --- | --- | --- |
|  | 2 | **LS 10 - Building - Zone 3** |  | 2011-09-13 | 2013-02-25 |  |  |  |  |  |  |  |  |  |  |
| 1.4.2.3.6.010 |  | Excavation leveling & compaction for LS10 | 25d | 2011-09-13 A | 2011-12-19 A | 1.2.6.200, Z2.2030 SS | 100% |  | 2011-08-08 | 2011-08-30 |  |  | SSH-Construction Manhours [766.12 h]; Excavator [100 h]; Dump Truck [100 h] | 15,000 |  |
| 1.4.2.3.6.020 |  | Install lean concrete & water proofing works LS10 | 31.25d | 2011-12-10 A | 2011-12-28 A | 1.4.2.3.6.010 | 100% |  | 2011-08-31 | 2011-09-28 |  |  | SSH-Construction Manhours [862.09 h] | 32,500 |  |
| 1.4.2.3.6.025 |  | Install base slab for LS10 | 31.25d | 2012-02-18 A | 2012-03-17 A | 1.4.2.3.6.020 | 100% |  |  |  |  |  | SSH-Construction Manhours [1115.97 h] | 20,000 |  |
| 1.4.2.3.6.030 |  | Construction for retaining walls LS10 | 25d | 2012-03-18 A | 2012-10-04 | 1.4.2.3.6.020, 1.4.2.3.6.025 | 95% | 1.25d | 2012-03-18 | 2012-04-09 | -147.5d | 0d | SSH-Construction Manhours [1673.96 h] | 4,000 |  |
| 1.4.2.3.6.040 |  | Constrcution for sump pit LS10 | 25d | 2012-03-27 A | 2012-04-18 A | 1.3.1.14.020 SS, 1.4.2.3.6.025, 1.4.2.3.6.030 FF+10d | 100% |  |  |  |  |  | SSH-Construction Manhours [3905.91 h] | 53,000 |  |
| 1.4.2.3.6.050 |  | Construction for top slab LS10 | 31.25d | 2012-04-19 A | 2012-11-08 | 1.4.2.3.6.040 | 14% | 26.88d | 2012-04-19 | 2012-05-17 | -95d | 0d | SSH-Construction Manhours [3905.91 h] | 72,750 |  |
| 1.4.2.3.6.060 |  | Construction of wall with water proofing LS10 | 37.5d | 2012-05-19 A | 2012-11-14 | 1.4.2.3.6.050 | 83% | 6.38d | 2012-05-19 | 2012-06-21 | -95d | 0d | SSH-Construction Manhours [3905.91 h] | 66,250 |  |
| 1.4.2.3.6.070 |  | Backfilling & Compaction LS10 | 12.5d | 2012-11-08 | 2012-11-20 | 1.4.2.3.6.060 FF+6.25d |  |  |  |  | -95d | 0d | SSH-Construction Manhours [766.12 h] | 53,000 |  |
| 1.4.2.3.6.080 |  | Plastering & Painting work LS10 -Door installation | 31.25d | 2012-11-20 | 2012-12-19 | 1.4.2.3.6.070 |  |  |  |  | -95d | 0d | SSH-Construction Manhours [1676.75 h] | 11,250 |  |
| 1.4.2.3.6.130 |  | Install precast concrete fence & gate LS10 | 30d | 2012-12-01 | 2012-12-29 | 1.4.2.3.6.080 FF+10d |  |  |  |  | -95d | 0d | SSH-Construction Manhours [1609.24 h] | 219,000 |  |
| 1.4.2.3.6.150 |  | Install piping system & odour control sytem | 31.25d | 2012-12-27 | 2013-01-26 | 1.4.2.3.6.140 FF, 1.3.4.8.030 |  |  |  |  | -95d | 0d | SSH-Construction Manhours [1197.44 h]; Welding Machine [250 h] | 12,500 |  |
| 1.4.2.3.6.155 |  | Install electrical/instr work/fire detection system LS10 | 31.25d | 2012-12-27 | 2013-01-26 | 1.4.2.3.6.150 FF |  |  |  |  | -95d | 0d | SSH-Construction Manhours [948.58 h] | 12,500 | 0.0036924591 |
| 1.4.2.3.6.140 |  | Install asphalt pavement LS10 | 30d | 2012-12-29 | 2013-01-26 | 1.4.2.3.6.130 |  |  |  |  | -95d | 0d | SSH-Construction Manhours [689.67 h] | 25,350 |  |
| 1.4.2.3.6.151 |  | Install Instruments & local control panel & accs | 30d | 2012-12-29 | 2013-01-26 | 1.4.2.3.6.150 FF |  |  |  |  | -80d | 0d | SSH-Construction Manhours [976.48 h] | 39,000 |  |
| 1.4.2.3.6.152 |  | Install odour control system cabling & instruments | 30d | 2012-12-29 | 2013-01-26 | 1.4.2.3.6.151 FF |  |  |  |  | -80d | 15d | SSH-Construction Manhours [976.48 h] | 39,000 |  |
| 1.4.2.3.6.160 |  | Testing & Commissioning of LS 10 | 18d | 2013-02-09 | 2013-02-25 | 1.4.2.3.6.155, 1.4.3.1.1.570, 1.4.3.1.2.570, M2.10, 1.4.2.7.4.120, 1.4.2.3.6.152 |  |  |  |  | -95d | 107.5d | SSH-Construction Manhours [578.07 h] | 10,000 |  |
|  | 3 | **LS 11 - Building - Zone 3** |  | 2011-11-15 | 2013-04-28 |  |  |  |  |  |  |  |  |  |  |
| 1.4.2.3.7.010 |  | Excavation leveling & compaction for LS11 | 25d | 2011-11-15 A | 2012-01-25 A | 1.4.2.3.6.010 SS | 100% |  | 2011-08-31 | 2011-09-22 |  |  | SSH-Construction Manhours [766.12 h]; Excavator [100 h]; Dump Truck [100 h] | 15,000 |  |
| 1.4.2.3.7.020 |  | Install lean concrete & water proofing works LS11 | 31.25d | 2012-02-18 A | 2012-03-17 A | 1.4.2.3.7.010 | 100% |  |  |  |  |  | SSH-Construction Manhours [862.09 h] | 32,500 |  |
| 1.4.2.3.7.025 |  | Install base slab for LS11 | 12.5d | 2012-03-18 A | 2012-10-04 | 1.4.2.3.7.020 | 90% | 1.25d | 2012-03-18 | 2012-03-28 | -161d | 0d | SSH-Construction Manhours [1115.97 h] | 20,000 |  |
| 1.4.2.3.7.040 |  | Constrcution for sump pit LS11 | 25d | 2012-04-08 A | 2012-11-06 | 1.4.2.3.7.030 FF+10d | 20% | 20d | 2012-04-08 | 2012-04-30 | -161d | 0d | SSH-Construction Manhours [3905.91 h] | 47,000 |  |
| 1.4.2.3.7.030 |  | Construction for retaining walls LS11 | 25d | 2012-10-06 | 2012-10-28 | 1.4.2.3.7.025 |  |  |  |  | -161d | 0d | SSH-Construction Manhours [1673.96 h] | 4,000 |  |
| 1.4.2.3.7.050 |  | Construction for top slab LS11 | 31.25d | 2012-11-07 | 2012-12-05 | 1.4.2.3.7.040 |  |  |  |  | -161d | 0d | SSH-Construction Manhours [3905.91 h] | 62,250 |  |
| 1.4.2.3.7.060 |  | Construction of wall with water proofing LS11 | 37.5d | 2012-12-10 | 2013-01-13 | 1.4.2.3.7.050 SS+35d |  |  |  |  | -161d | 0d | SSH-Construction Manhours [3905.91 h] | 58,750 |  |
| 1.4.2.3.7.070 |  | Backfilling & Compaction LS11 | 12.5d | 2013-01-08 | 2013-01-19 | 1.4.2.3.7.060 FF+6.25d |  |  |  |  | -161d | 0d | SSH-Construction Manhours [1340.84 h] | 47,000 |  |
| 1.4.2.3.7.080 |  | Plastering & Painting work LS11 -Door installation | 20d | 2013-01-20 | 2013-02-06 | 1.4.2.3.7.070, 1.4.2.3.7.020 SS |  |  |  |  | -161d | 0d | SSH-Construction Manhours [766.12 h]; Dump Truck [160 h] | 11,250 |  |
| 1.4.2.3.7.130 |  | Install precast concrete fence & gate LS11 | 30d | 2013-01-20 | 2013-02-16 | 1.4.2.3.7.080 FF+10d |  |  |  |  | -161d | 0d | SSH-Construction Manhours [1149.45 h] | 200,000 |  |
| 1.4.2.3.7.140 |  | Install asphalt pavement LS11 | 25d | 2013-02-17 | 2013-03-11 | 1.4.2.3.7.130 |  |  |  |  | -161d | 0d | SSH-Construction Manhours [958.06 h] | 22,650 |  |
| 1.4.2.3.7.150 |  | Install piping System & odour control system | 31.25d | 2013-02-25 | 2013-03-25 | 1.4.2.3.7.140 FF+15d |  |  |  |  | -161d | 0d | SSH-Construction Manhours [1197.44 h]; Welding Machine [250 h] | 11,000 |  |
| 1.4.2.3.7.155 |  | Install electrical/instr work / fire alarm system LS11 | 31.25d | 2013-02-25 | 2013-03-25 | 1.4.2.3.7.150 FF |  |  |  |  | -161d | 0d | SSH-Construction Manhours [974.25 h] | 11,000 | 0.003249364 |
| 1.4.2.3.7.151 |  | Install instruments & local control panel & accs | 30d | 2013-02-26 | 2013-03-25 | 1.4.2.3.7.150 FF |  |  |  |  | -142d | 0d | SSH-Construction Manhours [948.58 h] | 38,000 |  |
| 1.4.2.3.7.152 |  | Install odour control system cabling & instruments | 30d | 2013-02-26 | 2013-03-25 | 1.4.2.3.7.151 FF |  |  |  |  | -142d | 19d | SSH-Construction Manhours [948.58 h] | 38,000 |  |
| 1.4.2.3.7.160 |  | Testing & Commissioning of LS 11 | 17d | 2013-04-13 | 2013-04-28 | 1.4.2.3.7.155, 1.4.3.1.1.570, 1.4.3.1.2.570, M2.10, 1.4.2.7.4.122, 1.4.2.3.7.152 |  |  |  |  | -161d | 41.5d | SSH-Construction Manhours [720.92 h] | 10,000 |  |

| ID | WBS | Activity | Duration | Start | Finish | Predecessors | Complete | Remaining | Planned start | Planned finish | Total float | Free float | Resources | Cost | QTY |
| --- | --- | --- | --- | --- | --- | --- | --- | --- | --- | --- | --- | --- | --- | --- | --- |
|  | 4 | **LS 12 - Building - Zone 2** |  | 2011-11-28 | 2013-06-05 |  |  |  |  |  |  |  |  |  |  |
| 1.4.2.3.8.010 |  | Excavation leveling & compaction for LS12 | 25d | 2011-11-28 A | 2012-01-25 A | 1.4.2.3.7.010 SS | 100% |  | 2011-09-28 | 2011-10-20 |  |  | SSH-Construction Manhours [766.12 h]; Excavator [100 h]; Dump Truck [100 h] | 15,000 |  |
| 1.4.2.3.8.020 |  | Install lean concrete & water proofing works LS12 | 12.5d | 2012-10-04 | 2012-10-15 | 1.4.2.3.8.010 FF |  |  |  |  | -202.5d | 0d | SSH-Construction Manhours [862.09 h] | 32,500 |  |
| 1.4.2.3.8.025 |  | Install base slab for LS12 | 18.75d | 2012-10-16 | 2012-11-01 | 1.4.2.3.8.020 |  |  |  |  | -202.5d | 0d | SSH-Construction Manhours [1115.97 h] | 20,000 |  |
| 1.4.2.3.8.030 |  | Construction for retaining walls LS12 | 25d | 2012-11-03 | 2012-11-25 | 1.4.2.3.8.025 |  |  |  |  | -202.5d | 0d | SSH-Construction Manhours [1673.96 h] | 4,000 |  |
| 1.4.2.3.8.040 |  | Constrcution for sump pit LS12 | 25d | 2012-11-12 | 2012-12-04 | 1.4.2.3.8.030 FF+10d |  |  |  |  | -202.5d | 0d | SSH-Construction Manhours [3905.91 h] | 53,000 |  |
| 1.4.2.3.8.050 |  | Construction for top slab LS12 | 31.25d | 2012-12-05 | 2013-01-02 | 1.4.2.3.8.040 |  |  |  |  | -202.5d | 0d | SSH-Construction Manhours [3905.91 h] | 92,750 |  |
| 1.4.2.3.8.060 |  | Construction of wall with water proofing LS12 | 31.25d | 2013-01-03 | 2013-01-31 | 1.4.2.3.8.050 |  |  |  |  | -202.5d | 0d | SSH-Construction Manhours [3905.91 h] | 46,250 |  |
| 1.4.2.3.8.070 |  | Backfilling & Compaction LS12 | 12.5d | 2013-01-27 | 2013-02-06 | 1.4.2.3.8.060 FF+6.25d |  |  |  |  | -202.5d | 0d | SSH-Construction Manhours [766.12 h] | 53,000 |  |
| 1.4.2.3.8.080 |  | Plastering & Painting work LS11 -Door installation | 20d | 2013-02-07 | 2013-02-25 | 1.4.2.3.8.070, 1.4.2.3.8.020 SS |  |  |  |  | -202.5d | 0d | SSH-Construction Manhours [766.12 h]; Dump Truck [160 h] | 11,250 |  |
| 1.4.2.3.8.130 |  | Install precast concrete fence & gate LS12 | 30d | 2013-02-07 | 2013-03-06 | 1.4.2.3.8.080 FF+10d |  |  |  |  | -202.5d | 0d | SSH-Construction Manhours [1149.45 h] | 232,000 |  |
| 1.4.2.3.8.150 |  | Install piping System & odour control system | 43.75d | 2013-02-28 | 2013-04-09 | 1.4.2.3.8.140 FF+6.25d |  |  |  |  | -202.5d | 0d | SSH-Construction Manhours [1197.44 h]; Welding Machine [350 h] | 12,675 |  |
| 1.4.2.3.8.140 |  | Install asphalt pavement LS12 | 30d | 2013-03-07 | 2013-04-03 | 1.4.2.3.8.130 |  |  |  |  | -202.5d | 0d | SSH-Construction Manhours [919.56 h] | 25,000 |  |
| 1.4.2.3.8.151 |  | Install instruments & local control panel & accs | 30d | 2013-03-13 | 2013-04-09 | 1.4.2.3.8.150 FF |  |  |  |  | -171.25d | 0d | SSH-Construction Manhours [1171.77 h] | 39,000 |  |
| 1.4.2.3.8.152 |  | Install odour control system cabling & instruments | 30d | 2013-03-13 | 2013-04-09 | 1.4.2.3.8.151 FF |  |  |  |  | -171.25d | 31.25d | SSH-Construction Manhours [1171.77 h] | 39,000 |  |
| 1.4.2.3.8.155 |  | Install electrical/instr work / fire alarm system LS12 | 31.25d | 2013-03-18 | 2013-04-15 | 1.4.2.3.8.150 FF+6.25d |  |  |  |  | -202.5d | 0d | SSH-Construction Manhours [1169.54 h] | 12,675 | 0.0037441535 |
| 1.4.2.3.8.160 |  | Testing & Commissioning of LS 12 | 30d | 2013-05-09 | 2013-06-05 | 1.4.2.3.8.155, 1.4.3.1.1.570, 1.4.3.1.2.570, M2.10, 1.4.2.7.4.124, 1.4.2.3.8.152 |  |  |  |  | -202.5d | 0d | SSH-Construction Manhours [768.91 h] | 10,000 |  |
|  | 3 | **Storm Water Drainage System** |  | 2012-03-04 | 2013-05-23 |  |  |  |  |  |  |  |  |  |  |
|  | 1 | **Zone 1** |  | 2012-03-04 | 2012-10-25 |  |  |  |  |  |  |  |  |  |  |
|  | 1 | **Storm Drainage Ditches** |  | 2012-03-04 | 2012-10-25 |  |  |  |  |  |  |  |  |  |  |
| 1.4.2.4.1.020 |  | Construction of concrete drainage ditch | 25d | 2012-03-04 A | 2012-10-24 | 1.4.2.4.1.010 | 60% | 10d | 2012-03-04 | 2012-03-27 | -114.69d | 0d | SSH-Construction Manhours [1093.19 h] | 154,500 |  |
| 1.4.2.4.1.015 |  | Leveling -compaction of drainage ditch | 31.25d | 2012-04-02 A | 2012-10-25 | 1.4.2.4.1.020 SS+31.25d | 65% | 10.94d | 2012-04-02 | 2012-05-01 | -114.69d | 0d | SSH-Construction Manhours [1093.19 h] | 12,000 | 0.0035447607 |
| 1.4.2.4.1.010 |  | Excavation for storm water drainage ditch (750LM) | 25d | 2012-04-12 A | 2012-10-15 | 1.4.2.3.8.010 FF | 50% | 12.5d | 2012-04-12 | 2012-05-05 | -156.25d | 0d | SSH-Construction Manhours [874.34 h] | 9,000 |  |
|  | 2 | **Zone 2** |  | 2012-08-02 | 2013-03-28 |  |  |  |  |  |  |  |  |  |  |
|  | 1 | **Storm Drainage Ditches** |  | 2012-10-25 | 2013-03-28 |  |  |  |  |  |  |  |  |  |  |
| 1.4.2.4.2.090A |  | Excavation for storm water drainage ditch (2550LM)A | 10d | 2012-10-25 | 2012-11-04 | 1.4.2.4.1.015 |  |  |  |  | -114.69d | 0d | SSH-Construction Manhours [349.74 h] | 11,250 |  |
| 1.4.2.4.2.090B |  | Leveling - compaction of drainage ditchA | 12.5d | 2012-11-04 | 2012-11-15 | 1.4.2.4.2.090A |  |  |  |  | -95.94d | 0d | SSH-Construction Manhours [437.17 h] | 15,000 |  |
| 1.4.2.4.2.090C |  | Construction of concrete drainage ditchA | 45d | 2012-11-15 | 2012-12-27 | 1.4.2.4.2.090B |  |  |  |  | -95.94d | 0d | SSH-Construction Manhours [819.76 h] | 193,125 |  |
| 1.4.2.4.2.091A |  | Excavation for storm water drainage ditch (2550LM)B | 10d | 2012-11-25 | 2012-12-04 | 1.4.2.4.2.090C SS+10d |  |  |  |  | -95.94d | 0d | SSH-Construction Manhours [377.29 h] | 11,250 |  |
| 1.4.2.4.2.091B |  | Leveling - compaction of drainage ditchB | 12.5d | 2012-12-04 | 2012-12-16 | 1.4.2.4.2.091A |  |  |  |  | -95.94d | 0d | SSH-Construction Manhours [437.17 h] | 15,000 |  |
| 1.4.2.4.2.091C |  | Construction of concrete drainage ditchB | 45d | 2012-12-16 | 2013-01-27 | 1.4.2.4.2.091B |  |  |  |  | -95.94d | 0d | SSH-Construction Manhours [819.76 h] | 193,125 |  |
| 1.4.2.4.2.092A |  | Excavation for storm water drainage ditch (2550LM)C | 10d | 2012-12-25 | 2013-01-03 | 1.4.2.4.2.091C SS+10d |  |  |  |  | -95.94d | 0d | SSH-Construction Manhours [349.74 h] | 11,250 |  |
| 1.4.2.4.2.092B |  | Leveling - compaction of drainage ditchC | 12.5d | 2013-01-03 | 2013-01-15 | 1.4.2.4.2.092A |  |  |  |  | -95.94d | 0d | SSH-Construction Manhours [437.17 h] | 15,000 |  |
| 1.4.2.4.2.092D |  | Construction of concrete drainage ditchC | 45d | 2013-01-15 | 2013-02-26 | 1.4.2.4.2.092B |  |  |  |  | -95.94d | 0d | SSH-Construction Manhours [656.02 h] | 193,125 |  |
| 1.4.2.4.2.093A |  | Excavation for storm water drainage ditch (2550LM)D | 10d | 2013-01-24 | 2013-02-03 | 1.4.2.4.2.092D SS+10d |  |  |  |  | -95.94d | 0d | SSH-Construction Manhours [349.74 h] | 11,250 |  |
| 1.4.2.4.2.093B |  | Leveling - compaction of drainage ditchD | 12.5d | 2013-02-03 | 2013-02-14 | 1.4.2.4.2.093A |  |  |  |  | -95.94d | 0d | SSH-Construction Manhours [437.17 h] | 15,000 |  |
| 1.4.2.4.2.093C |  | Construction of concrete drainage ditchD | 45d | 2013-02-14 | 2013-03-28 | 1.4.2.4.2.093B |  |  |  |  | -95.94d | 60.31d | SSH-Construction Manhours [819.76 h] | 193,124 |  |

| ID | WBS | Activity | Duration | Start | Finish | Predecessors | Complete | Remaining | Planned start | Planned finish | Total float | Free float | Resources | Cost |
| --- | --- | --- | --- | --- | --- | --- | --- | --- | --- | --- | --- | --- | --- | --- |
|  | 2 | **Strom Drainage Ponds & Box Culverts** |  | 2012-08-02 | 2013-03-28 |  |  |  |  |  |  |  |  |  |
| 1.4.2.4.2.053A |  | Excavation for Box culvert-4 | 7.5d | 2012-08-02 A | 2012-08-09 A | 1.4.2.4.2.052C SS+20d | 100% |  |  |  |  |  | SSH-Construction Manhours [262.3 h] | 18,000 |
| 1.4.2.4.2.053B |  | Leveling -compaction of box culvert-4 | 7.5d | 2012-08-09 A | 2013-01-31 | 1.4.2.4.2.053A | 35% | 4.88d | 2012-08-09 | 2012-08-16 | -95.81d | 0d | SSH-Construction Manhours [262.3 h] | 5,000 |
| 1.4.2.4.2.010 |  | Excavation for storm water drainage pond | 10d | 2012-11-04 | 2012-11-13 | 1.4.2.4.2.090A |  |  |  |  | -114.69d | 0d | SSH-Construction Manhours [349.74 h]; Excavator [80 h]; Dump Truck [80 h] | 199,889 |
| 1.4.2.4.2.050A |  | Excavation for Box culvert-1 | 7.5d | 2012-11-04 | 2012-11-11 | 1.4.2.4.2.010 SS |  |  |  |  | -95.81d | 0d | SSH-Construction Manhours [262.3 h] | 18,000 |
| 1.4.2.4.2.050B |  | Leveling -compaction of box culvert-1 | 7.5d | 2012-11-11 | 2012-11-18 | 1.4.2.4.2.050A |  |  |  |  | -95.81d | 0d | SSH-Construction Manhours [262.3 h] | 5,000 |
| 1.4.2.4.2.020 |  | Construction of RC spillways | 45d | 2012-11-13 | 2012-12-25 | 1.4.2.4.2.010 |  |  |  |  | -40.94d | 0d | SSH-Construction Manhours [1749.21 h] | 150,000 |
| 1.4.2.4.2.050C |  | Construction of box culvert-1 | 60d | 2012-11-18 | 2013-01-13 | 1.4.2.4.2.050B |  |  |  |  | -95.81d | 0d | SSH-Construction Manhours [7652.35 h] | 150,000 |
| 1.4.2.4.2.051A |  | Excavation for Box culvert-2 | 7.5d | 2012-12-06 | 2012-12-13 | 1.4.2.4.2.050C SS+20d |  |  |  |  | -95.81d | 0d | SSH-Construction Manhours [262.3 h] | 18,000 |
| 1.4.2.4.2.051B |  | Leveling -compaction of box culvert-2 | 7.5d | 2012-12-13 | 2012-12-20 | 1.4.2.4.2.051A |  |  |  |  | -95.81d | 0d | SSH-Construction Manhours [262.3 h] | 5,000 |
| 1.4.2.4.2.051C |  | Construction of box culvert-2 | 60d | 2012-12-13 | 2013-02-07 | 1.4.2.4.2.051B SS |  |  |  |  | -95.81d | 0d | SSH-Construction Manhours [1366.62 h] | 150,000 |
| 1.4.2.4.2.015 |  | Leveling - compaction for drainage pond | 12.5d | 2012-12-25 | 2013-01-06 | 1.4.2.4.2.020 |  |  |  |  | -40.94d | 0d | SSH-Construction Manhours [437.17 h] | 120,000 |
| 1.4.2.4.2.052A |  | Excavation for Box culvert-3 | 7.5d | 2013-01-01 | 2013-01-08 | 1.4.2.4.2.051C SS+20d |  |  |  |  | -95.81d | 0d | SSH-Construction Manhours [262.3 h] | 18,000 |
| 1.4.2.4.2.052B |  | Leveling -compaction of box culvert-3 | 7.5d | 2013-01-08 | 2013-01-15 | 1.4.2.4.2.052A |  |  |  |  | -95.81d | 0d | SSH-Construction Manhours [262.3 h] | 5,000 |
| 1.4.2.4.2.052C |  | Construction of box culvert-3 | 60d | 2013-01-08 | 2013-03-05 | 1.4.2.4.2.052B SS |  |  |  |  | -95.81d | 0d | SSH-Construction Manhours [1093.19 h] | 150,000 |
| 1.4.2.4.2.040 |  | Marl caping for drainage pond | 25d | 2013-01-13 | 2013-02-05 | 1.4.2.4.2.015 SS+20d |  |  |  |  | -40.94d | 115.31d | SSH-Construction Manhours [874.34 h] | 125,000 |
| 1.4.2.4.2.054A |  | Excavation for Box culvert-5 | 7.5d | 2013-01-27 | 2013-02-03 | 1.4.2.4.2.053A SS+20d |  |  |  |  | -90.94d | 0d | SSH-Construction Manhours [127.18 h] | 18,000 |
| 1.4.2.4.2.053C |  | Construction of box culvert-4 | 60d | 2013-01-31 | 2013-03-28 | 1.4.2.4.2.053B |  |  |  |  | -95.81d | 60.44d | SSH-Construction Manhours [929.45 h] | 150,000 |
| 1.4.2.4.2.054B |  | Leveling -compaction of box culvert-5 | 7.5d | 2013-02-03 | 2013-02-10 | 1.4.2.4.2.054A |  |  |  |  | -90.94d | 0d | SSH-Construction Manhours [262.3 h] | 5,000 |
| 1.4.2.4.2.054C |  | Construction of box culvert-5 | 45d | 2013-02-10 | 2013-03-24 | 1.4.2.4.2.054B |  |  |  |  | -90.94d | 65.31d | SSH-Construction Manhours [262.3 h] | 150,000 |
|  | 3 | **Zone 3** |  | 2012-06-07 | 2013-04-15 |  |  |  |  |  |  |  |  |  |
|  | 1 | **Storm Drainage Ditches-A3-1** |  | 2012-11-13 | 2013-04-02 |  |  |  |  |  |  |  |  |  |
| 1.4.2.4.3.090A |  | Excavation for storm water drainage ditchA3-1-1 | 7.5d | 2012-11-13 | 2012-11-20 | 1.4.2.4.2.010 |  |  |  |  | -114.69d | 0d | SSH-Construction Manhours [393.72 h] | 84,063 |
| 1.4.2.4.3.090B |  | Leveling -compaction of drainage ditchA3-1-1 | 12.5d | 2012-11-20 | 2012-12-02 | 1.4.2.4.3.090A |  |  |  |  | -113.44d | 0d | SSH-Construction Manhours [656.02 h] | 42,547 |
| 1.4.2.4.3.090C |  | Construction of concrete drainage ditchA3-1-1 | 40d | 2012-12-02 | 2013-01-08 | 1.4.2.4.3.090B |  |  |  |  | -113.44d | 0d | SSH-Construction Manhours [984.03 h] | 298,811 |
| 1.4.2.4.3.092A |  | Excavation for storm water drainage ditchA3-1-2 | 7.5d | 2012-12-11 | 2012-12-18 | 1.4.2.4.3.090C SS+10d |  |  |  |  | -113.44d | 0d | SSH-Construction Manhours [262.3 h] | 84,063 |
| 1.4.2.4.3.092B |  | Leveling -compaction of drainage ditchA3-1-2 | 12.5d | 2012-12-18 | 2012-12-30 | 1.4.2.4.3.092A |  |  |  |  | -100.94d | 0d | SSH-Construction Manhours [437.17 h] | 42,547 |
| 1.4.2.4.3.092C |  | Construction of concrete drainage ditchA3-1-2 | 40d | 2012-12-30 | 2013-02-05 | 1.4.2.4.3.092B |  |  |  |  | -100.94d | 0d | SSH-Construction Manhours [819.76 h] | 298,811 |
| 1.4.2.4.3.094A |  | Excavation for storm water drainage ditchA3-1-3 | 7.5d | 2013-01-08 | 2013-01-15 | 1.4.2.4.3.092C SS+10d |  |  |  |  | -100.94d | 0d | SSH-Construction Manhours [262.3 h] | 84,063 |
| 1.4.2.4.3.094B |  | Leveling -compaction of drainage ditchA3-1-3 | 12.5d | 2013-01-15 | 2013-01-27 | 1.4.2.4.3.094A |  |  |  |  | -100.94d | 0d | SSH-Construction Manhours [437.17 h] | 42,547 |
| 1.4.2.4.3.094C |  | Construction of concrete drainage ditchA3-1-3 | 40d | 2013-01-27 | 2013-03-05 | 1.4.2.4.3.094B |  |  |  |  | -100.94d | 0d | SSH-Construction Manhours [819.76 h] | 298,811 |
| 1.4.2.4.3.096A |  | Excavation for storm water drainage ditchA3-1-4 | 7.5d | 2013-02-05 | 2013-02-12 | 1.4.2.4.3.094C SS+10d |  |  |  |  | -100.94d | 0d | SSH-Construction Manhours [262.3 h] | 84,063 |
| 1.4.2.4.3.096B |  | Leveling -compaction of drainage ditchA3-1-4 | 12.5d | 2013-02-12 | 2013-02-24 | 1.4.2.4.3.096A |  |  |  |  | -100.94d | 0d | SSH-Construction Manhours [437.17 h] | 42,547 |
| 1.4.2.4.3.096C |  | Construction of concrete drainage ditchA3-1-4 | 40d | 2013-02-24 | 2013-04-02 | 1.4.2.4.3.096B |  |  |  |  | -100.94d | 12.5d | SSH-Construction Manhours [819.76 h] | 298,811 |

| ID | WBS | Activity | Duration | Start | Finish | Predecessors | Complete | Remaining | Planned start | Planned finish | Total float | Free float | Resources | Cost |
| --- | --- | --- | --- | --- | --- | --- | --- | --- | --- | --- | --- | --- | --- | --- |
|  | 2 | **Strom Drainage Ponds-A3-1** |  | 2012-12-11 | 2013-04-14 |  |  |  |  |  |  |  |  |  |
| 1.4.2.4.3.010 |  | Excavation for storm water drainage pond (1) | 7.5d | 2012-12-11 | 2012-12-18 | 1.4.2.4.3.092A FF |  |  |  |  | -113.44d | 0d | SSH-Construction Manhours [328.01 h]; Excavator [60 h]; Dump Truck [60 h] | 84,063 |
| 1.4.2.4.3.015 |  | Leveling- compaction for drainage pond | 15d | 2012-12-18 | 2013-01-01 | 1.4.2.4.3.010 |  |  |  |  | -113.44d | 0d | SSH-Construction Manhours [656.02 h] | 42,547 |
| 1.4.2.4.3.020 |  | Construction of RC spillwaysA | 25d | 2013-01-01 | 2013-01-24 | 1.4.2.4.3.015 |  |  |  |  | -113.44d | 0d | SSH-Construction Manhours [1312.04 h] | 49,405 |
| 1.4.2.4.3.030 |  | Construction of RC spillwaysB | 25d | 2013-01-20 | 2013-02-12 | 1.4.2.4.3.020 FF+20d |  |  |  |  | -113.44d | 0d | SSH-Construction Manhours [1312.04 h] | 49,406 |
| 1.4.2.4.3.040 |  | Marl caping for drainage pond | 25d | 2013-02-12 | 2013-03-07 | 1.4.2.4.3.020, 1.4.2.4.3.030 |  |  |  |  | -113.44d | 0d | SSH-Construction Manhours [874.34 h] | 360,000 |
| 1.4.2.4.3.050 |  | Excavation for Box culvert | 7.5d | 2013-02-12 | 2013-02-19 | 1.4.2.4.3.040 SS |  |  |  |  | -113.44d | 0d | SSH-Construction Manhours [262.3 h] | 30,000 |
| 1.4.2.4.3.060 |  | Leveling -compaction of box culvert | 7.5d | 2013-02-19 | 2013-02-26 | 1.4.2.4.3.050 |  |  |  |  | -113.44d | 0d | SSH-Construction Manhours [262.3 h] | 20,000 |
| 1.4.2.4.3.070 |  | Construction of box culvert | 50d | 2013-02-26 | 2013-04-14 | 1.4.2.4.3.060, 1.4.2.4.3.096C FF |  |  |  |  | -113.44d | 42.81d | SSH-Construction Manhours [929.45 h] | 100,000 |
|  | 3 | **Storm Drainage Ditches-A3-2** |  | 2012-11-20 | 2013-04-15 |  |  |  |  |  |  |  |  |  |
| 1.4.2.4.3.100A |  | Excavation for storm water drainage ditchA3-2.-1 | 18.75d | 2012-11-20 | 2012-12-08 | 1.4.2.4.3.090A, M1.07 |  |  |  |  | -114.69d | 0d | SSH-Construction Manhours [656.02 h] | 84,063 |
| 1.4.2.4.3.100B |  | Leveling -compaction of drainage ditchA3-2-1 | 15d | 2012-12-08 | 2012-12-22 | 1.4.2.4.3.100A |  |  |  |  | -114.69d | 0d | SSH-Construction Manhours [524.61 h] | 42,547 |
| 1.4.2.4.3.100C |  | Construction of concrete drainage ditchA3-2-1 | 45d | 2012-12-22 | 2013-02-02 | 1.4.2.4.3.100B |  |  |  |  | -98.44d | 0d | SSH-Construction Manhours [1093.19 h] | 298,811 |
| 1.4.2.4.3.104A |  | Excavation for storm water drainage ditchA3-2-3 | 18.75d | 2012-12-22 | 2013-01-08 | 1.4.2.4.3.100B |  |  |  |  | -114.69d | 0d | SSH-Construction Manhours [656.02 h] | 84,063 |
| 1.4.2.4.3.102A |  | Excavation for storm water drainage ditchA3-2-2 | 18.75d | 2013-01-05 | 2013-01-22 | 1.4.2.4.3.100C SS+15d |  |  |  |  | -98.44d | 0d | SSH-Construction Manhours [656.02 h] | 84,063 |
| 1.4.2.4.3.104B |  | Leveling -compaction of drainage ditchA3-2-3 | 12.5d | 2013-01-08 | 2013-01-20 | 1.4.2.4.3.104A |  |  |  |  | -114.69d | 0d | SSH-Construction Manhours [765.18 h] | 42,547 |
| 1.4.2.4.3.104C |  | Construction of concrete drainage ditchA3-2-3 | 45d | 2013-01-20 | 2013-03-03 | 1.4.2.4.3.104B |  |  |  |  | -114.69d | 0d | SSH-Construction Manhours [1093.19 h] | 298,811 |
| 1.4.2.4.3.102B |  | Leveling -compaction of drainage ditchA3-2-2 | 12.5d | 2013-01-22 | 2013-02-03 | 1.4.2.4.3.102A |  |  |  |  | -98.44d | 0d | SSH-Construction Manhours [437.17 h] | 42,547 |
| 1.4.2.4.3.102C |  | Construction of concrete drainage ditchA3-2-2 | 45d | 2013-02-03 | 2013-03-17 | 1.4.2.4.3.102B |  |  |  |  | -98.44d | 16.25d | SSH-Construction Manhours [1093.19 h] | 298,811 |
| 1.4.2.4.3.106A |  | Excavation for storm water drainage ditchA3-2-4 | 18.75d | 2013-02-03 | 2013-02-20 | 1.4.2.4.3.104C SS+15d |  |  |  |  | -114.69d | 0d | SSH-Construction Manhours [819.76 h] | 84,063 |
| 1.4.2.4.3.106B |  | Leveling -compaction of drainage ditchA3-2-4 | 12.5d | 2013-02-20 | 2013-03-04 | 1.4.2.4.3.106A |  |  |  |  | -114.69d | 0d | SSH-Construction Manhours [546.86 h] | 42,547 |
| 1.4.2.4.3.106C |  | Construction of concrete drainage ditchA3-2-4 | 45d | 2013-03-04 | 2013-04-15 | 1.4.2.4.3.106B, 1.4.2.4.3.102C SS+15d |  |  |  |  | -114.69d | 41.56d | SSH-Construction Manhours [1312.04 h] | 298,811 |
|  | 5 | **Storm Drainage Ditches & Box Culvert -A3-3** |  | 2012-06-13 | 2013-04-02 |  |  |  |  |  |  |  |  |  |
| 1.4.2.4.3.110A |  | Excavation for storm water drainage ditchA3-3-1 | 18.75d | 2012-06-13 A | 2012-12-20 | 1.4.2.4.3.100A | 25% | 14.06d | 2012-06-13 | 2012-07-01 | -103.9d | 0d | SSH-Construction Manhours [656.02 h] | 84,063 |
| 1.4.2.4.3.110B |  | Leveling -compaction of drainage ditchA3-3-1 | 15d | 2012-07-01 A | 2013-01-02 | 1.4.2.4.3.110A | 16% | 12.6d | 2012-07-01 | 2012-07-15 | -100.1d | 0d | SSH-Construction Manhours [524.61 h] | 42,547 |
| 1.4.2.4.3.110C |  | Construction of concrete drainage ditchA3-3-1 | 45d | 2012-07-15 A | 2013-02-04 | 1.4.2.4.3.110B | 20% | 36d | 2012-07-15 | 2012-08-26 | -90.1d | 0d | SSH-Construction Manhours [1093.19 h] | 298,811 |
| 1.4.2.4.3.114A |  | Excavation for storm water drainage ditchA3-3-3 | 18.75d | 2012-12-16 | 2013-01-02 | 1.4.2.4.3.110B FF |  |  |  |  | -100.1d | 0d | SSH-Construction Manhours [656.02 h] | 84,063 |
| 1.4.2.4.3.112A |  | Excavation for storm water drainage ditchA3-3-2 | 18.75d | 2013-01-02 | 2013-01-20 | 1.4.2.4.3.110C SS+15d |  |  |  |  | -90.1d | 0d | SSH-Construction Manhours [656.02 h] | 84,063 |
| 1.4.2.4.3.114B |  | Leveling -compaction of drainage ditchA3-3-3 | 12.5d | 2013-01-02 | 2013-01-14 | 1.4.2.4.3.114A |  |  |  |  | -100.1d | 0d | SSH-Construction Manhours [437.17 h] | 42,547 |
| 1.4.2.4.3.114C |  | Construction of concrete drainage ditchA3-3-3 | 45d | 2013-01-14 | 2013-02-25 | 1.4.2.4.3.114B |  |  |  |  | -100.1d | 0d | SSH-Construction Manhours [1093.19 h] | 298,811 |
| 1.4.2.4.3.112B |  | Leveling -compaction of drainage ditchA3-3-2 | 12.5d | 2013-01-20 | 2013-01-31 | 1.4.2.4.3.112A |  |  |  |  | -90.1d | 0d | SSH-Construction Manhours [437.17 h] | 42,547 |
| 1.4.2.4.3.116A |  | Excavation for storm water drainage ditchA3-3-4 | 18.75d | 2013-01-28 | 2013-02-14 | 1.4.2.4.3.114C SS+15d |  |  |  |  | -100.1d | 0d | SSH-Construction Manhours [656.02 h] | 84,063 |
| 1.4.2.4.3.112C |  | Construction of concrete drainage ditchA3-3-2 | 45d | 2013-01-31 | 2013-03-14 | 1.4.2.4.3.112B |  |  |  |  | -90.1d | 10d | SSH-Construction Manhours [1093.19 h] | 298,811 |
| 1.4.2.4.3.116B |  | Leveling -compaction of drainage ditchA3-3-4 | 12.5d | 2013-02-14 | 2013-02-26 | 1.4.2.4.3.116A |  |  |  |  | -100.1d | 0d | SSH-Construction Manhours [437.17 h] | 42,547 |
| 1.4.2.4.3.116C |  | Construction of concrete drainage ditchA3-3-4 | 45d | 2013-02-19 | 2013-04-02 | 1.4.2.4.3.116B SS+5d, 1.4.2.4.3.112C SS+10d |  |  |  |  | -100.1d | 56.15d | SSH-Construction Manhours [743.46 h] | 298,811 |

| ID | WBS | Activity | Duration | Start | Finish | Predecessors | Complete | Remaining | Planned start | Planned finish | Total float | Free float | Resources | Cost |
| --- | --- | --- | --- | --- | --- | --- | --- | --- | --- | --- | --- | --- | --- | --- |
|  | 6 | **Strom Drainage Ponds -A3-3** |  | 2012-06-24 | 2013-04-06 |  |  |  |  |  |  |  |  |  |
| 1.4.2.4.3.310 |  | Excavation for storm water drainage pond (1) | 7.5d | 2012-06-24 A | 2012-12-20 | 1.4.2.4.3.110A FF | 10% | 6.75d | 2012-06-24 | 2012-07-01 | -103.9d | 0d | SSH-Construction Manhours [458.9 h]; Dump Truck [60 h]; Excavator [60 h] | 42,031 |
| 1.4.2.4.3.320 |  | Leveling- compaction for drainage pond | 10d | 2012-07-01 A | 2012-12-29 | 1.4.2.4.3.310 | 14% | 8.65d | 2012-07-01 | 2012-07-10 | -103.9d | 0d | SSH-Construction Manhours [437.17 h] | 21,273 |
| 1.4.2.4.3.330 |  | Construction of RC spillways | 25d | 2012-12-29 | 2013-01-21 | 1.4.2.4.3.320 |  |  |  |  | -103.9d | 0d | SSH-Construction Manhours [1749.21 h] | 99,405 |
| 1.4.2.4.3.340 |  | Marl caping for drainage pond | 10d | 2013-01-14 | 2013-01-23 | 1.4.2.4.3.330 FF+2d |  |  |  |  | -103.9d | 0d | SSH-Construction Manhours [2623.56 h] | 831 |
| 1.4.2.4.3.350 |  | Excavation for storm water drainage pond (2) | 7.5d | 2013-01-23 | 2013-01-30 | 1.4.2.4.3.340 |  |  |  |  | -103.9d | 0d | SSH-Construction Manhours [458.9 h] | 42,032 |
| 1.4.2.4.3.360 |  | Leveling- compaction for drainage pond | 7.5d | 2013-01-30 | 2013-02-06 | 1.4.2.4.3.350 |  |  |  |  | -103.9d | 0d | SSH-Construction Manhours [458.9 h] | 21,275 |
| 1.4.2.4.3.370 |  | Construction of RC spillways | 25d | 2013-02-06 | 2013-03-02 | 1.4.2.4.3.360 |  |  |  |  | -103.9d | 0d | SSH-Construction Manhours [1312.04 h] | 99,406 |
| 1.4.2.4.3.450 |  | Construction of box culvert | 50d | 2013-02-18 | 2013-04-06 | 1.4.2.4.3.400 FF+30d |  |  |  |  | -103.9d | 52.35d | SSH-Construction Manhours [929.45 h] | 100,000 |
| 1.4.2.4.3.380 |  | Marl caping for drainage pond | 10d | 2013-02-23 | 2013-03-04 | 1.4.2.4.3.370 FF+2d |  |  |  |  | -103.9d | 0d | SSH-Construction Manhours [2623.56 h] | 831 |
| 1.4.2.4.3.390 |  | Excavation for Box culvert | 7.5d | 2013-02-23 | 2013-03-02 | 1.4.2.4.3.380 SS |  |  |  |  | -103.9d | 0d | SSH-Construction Manhours [262.3 h] | 30,000 |
| 1.4.2.4.3.400 |  | Leveling -compaction of box culvert | 7.5d | 2013-03-02 | 2013-03-09 | 1.4.2.4.3.390 |  |  |  |  | -103.9d | 0d | SSH-Construction Manhours [262.3 h] | 20,000 |
|  | 7 | **Strom Drainage Ponds -A3-4** |  | 2012-06-07 | 2013-03-12 |  |  |  |  |  |  |  |  |  |
| 1.4.2.4.3.410 |  | Excavation for storm water drainage ditchA | 12.5d | 2012-06-07 A | 2012-10-11 | 1.4.2.4.1.010 SS | 30% | 8.75d | 2012-06-07 | 2012-06-19 | -156.25d | 0d | SSH-Construction Manhours [458.9 h]; Excavator [60 h]; Dump Truck [60 h] | 42,862 |
| 1.4.2.4.3.420 |  | Leveling -compaction of drainage ditchA | 20d | 2012-10-13 | 2012-10-30 | 1.4.2.4.3.410 |  |  |  |  | -156.25d | 0d | SSH-Construction Manhours [437.17 h] | 21,273 |
| 1.4.2.4.3.430 |  | Construction of concrete drainage ditchA | 45d | 2012-10-31 | 2012-12-11 | 1.4.2.4.3.420 |  |  |  |  | -156.25d | 0d | SSH-Construction Manhours [1749.21 h] | 74,405 |
| 1.4.2.4.3.440 |  | Excavation for storm water drainage ditchB | 15d | 2012-11-19 | 2012-12-02 | 1.4.2.4.3.430 SS+20d |  |  |  |  | -156.25d | 0d | SSH-Construction Manhours [349.74 h] | 42,863 |
| 1.4.2.4.3.460 |  | Leveling -compaction of drainage ditchB | 15d | 2012-12-03 | 2012-12-16 | 1.4.2.4.3.440 |  |  |  |  | -78.75d | 0d | SSH-Construction Manhours [437.17 h] | 21,274 |
| 1.4.2.4.3.470 |  | Construction of concrete drainage ditchB | 45d | 2012-12-17 | 2013-01-27 | 1.4.2.4.3.460 |  |  |  |  | -78.75d | 0d | SSH-Construction Manhours [1749.21 h] | 74,406 |
| 1.4.2.4.3.480 |  | Excavation for Box culvert A | 7.5d | 2013-01-05 | 2013-01-10 | 1.4.2.4.3.470 SS+20d |  |  |  |  | -78.75d | 0d | SSH-Construction Manhours [476.91 h] | 22,500 |
| 1.4.2.4.3.490 |  | Leveling -compaction of box culvertA | 7.5d | 2013-01-12 | 2013-01-17 | 1.4.2.4.3.480 |  |  |  |  | -66.25d | 0d | SSH-Construction Manhours [262.3 h] | 15,000 |
| 1.4.2.4.3.510 |  | Excavation for Box culvert B | 10d | 2013-01-12 | 2013-01-20 | 1.4.2.4.3.480 |  |  |  |  | -78.75d | 0d | SSH-Construction Manhours [262.3 h] | 22,500 |
| 1.4.2.4.3.500 |  | Construction of box culvertA | 45d | 2013-01-19 | 2013-02-28 | 1.4.2.4.3.490 |  |  |  |  | -66.25d | 90d | SSH-Construction Manhours [929.45 h] | 37,500 |
| 1.4.2.4.3.520 |  | Leveling -compaction of box culvertB | 10d | 2013-01-21 | 2013-01-29 | 1.4.2.4.3.510 |  |  |  |  | -78.75d | 0d | SSH-Construction Manhours [262.3 h] | 15,000 |
| 1.4.2.4.3.530 |  | Construction of box culvertB | 45d | 2013-01-30 | 2013-03-12 | 1.4.2.4.3.520 |  |  |  |  | -78.75d | 77.5d | SSH-Construction Manhours [929.45 h] | 37,500 |

| ID | WBS | Activity | Duration | Start | Finish | Predecessors | Total float | Free float | Resources | Cost | QTY |
| --- | --- | --- | --- | --- | --- | --- | --- | --- | --- | --- | --- |
|  | 8 | **Strom Drainage Ponds -A3-5** |  | 2012-12-03 | 2013-03-19 |  |  |  |  |  |  |
| 1.4.2.4.3.610 |  | Excavation for storm water drainage ditchA | 7.5d | 2012-12-03 | 2012-12-09 | 1.4.2.4.3.440 | -156.25d | 0d | SSH-Construction Manhours [458.9 h]; Excavator [60 h]; Dump Truck [60 h] | 42,862 |  |
| 1.4.2.4.3.620 |  | Leveling -compaction of drainage ditchA | 7.5d | 2012-12-10 | 2012-12-16 | 1.4.2.4.3.610 | -86.25d | 0d | SSH-Construction Manhours [437.17 h] | 21,273 |  |
| 1.4.2.4.3.630 |  | Construction of concrete drainage ditchA | 45d | 2012-12-17 | 2013-01-27 | 1.4.2.4.3.620 | -86.25d | 0d | SSH-Construction Manhours [1749.21 h] | 74,405 |  |
| 1.4.2.4.3.640 |  | Excavation for storm water drainage ditchB | 7.5d | 2012-12-31 | 2013-01-06 | 1.4.2.4.3.630 SS+15d | -86.25d | 0d | SSH-Construction Manhours [476.91 h] | 42,863 |  |
| 1.4.2.4.3.650 |  | Leveling -compaction of drainage ditchB | 7.5d | 2013-01-07 | 2013-01-13 | 1.4.2.4.3.640 | -86.25d | 0d | SSH-Construction Manhours [437.17 h] | 21,274 |  |
| 1.4.2.4.3.690 |  | Construction of box culvertA | 45d | 2013-01-09 | 2013-02-19 | 1.4.2.4.3.680 FF+10d | -86.25d | 0d | SSH-Construction Manhours [929.45 h] | 37,500 |  |
| 1.4.2.4.3.660 |  | Construction of concrete drainage ditchB | 45d | 2013-01-14 | 2013-02-24 | 1.4.2.4.3.650 | -86.25d | 0d | SSH-Construction Manhours [1749.21 h] | 74,406 |  |
| 1.4.2.4.3.720 |  | Construction of box culvertB | 60d | 2013-01-23 | 2013-03-19 | 1.4.2.4.3.710 FF+4d, 1.4.2.4.3.690 SS+15d | -86.25d | 70d | SSH-Construction Manhours [929.45 h] | 37,500 |  |
| 1.4.2.4.3.670 |  | Excavation for Box culvert A | 7.5d | 2013-01-28 | 2013-02-03 | 1.4.2.4.3.660 SS+15d | -86.25d | 0d | SSH-Construction Manhours [262.3 h] | 22,500 |  |
| 1.4.2.4.3.680 |  | Leveling -compaction of box culvertA | 7.5d | 2013-02-04 | 2013-02-10 | 1.4.2.4.3.670 | -86.25d | 0d | SSH-Construction Manhours [262.3 h] | 15,000 |  |
| 1.4.2.4.3.700 |  | Excavation for Box culvert B | 7.5d | 2013-02-04 | 2013-02-10 | 1.4.2.4.3.670 | -57.75d | 0d | SSH-Construction Manhours [476.91 h] | 22,500 |  |
| 1.4.2.4.3.710 |  | Leveling -compaction of box culvertB | 7.5d | 2013-02-11 | 2013-02-17 | 1.4.2.4.3.700 | -57.75d | 28.5d | SSH-Construction Manhours [262.3 h] | 15,000 |  |
|  | 4 | **Zone 4** |  | 2012-12-10 | 2013-05-23 |  |  |  |  |  |  |
|  | 1 | **Storm Drainage Ditches** |  | 2012-12-10 | 2013-04-14 |  |  |  |  |  |  |
| 1.4.2.4.4.110A |  | Excavation for storm water drainage ditch-A(1200LM) | 10d | 2012-12-10 | 2012-12-18 | 1.4.2.4.3.610, M2.06 | -156.25d | 0d | SSH-Construction Manhours [437.17 h] | 10,500 |  |
| 1.4.2.4.4.110B |  | Leveling -compaction of drainage ditch-A | 12.5d | 2012-12-19 | 2012-12-30 | 1.4.2.4.4.110A | -113.75d | 0d | SSH-Construction Manhours [1640.05 h] | 14,000 |  |
| 1.4.2.4.4.110C |  | Construction of concrete drainage ditch-A | 45d | 2012-12-31 | 2013-02-10 | 1.4.2.4.4.110B | -113.75d | 0d | SSH-Construction Manhours [1530.36 h] | 180,250 |  |
| 1.4.2.4.4.120A |  | Excavation for storm water drainage ditch-B(1200LM) | 10d | 2013-02-11 | 2013-02-19 | 1.4.2.4.4.110C | -113.75d | 0d | SSH-Construction Manhours [437.17 h] | 10,500 |  |
| 1.4.2.4.4.120B |  | Leveling -compaction of drainage ditch-B | 12.5d | 2013-02-20 | 2013-03-03 | 1.4.2.4.4.120A | -113.75d | 0d | SSH-Construction Manhours [546.86 h] | 14,000 | 0.0082711084 |
| 1.4.2.4.4.120C |  | Construction of concrete drainage ditch-B | 45d | 2013-03-04 | 2013-04-14 | 1.4.2.4.4.120B | -113.75d | 42.5d | SSH-Construction Manhours [918.32 h] | 180,250 |  |
|  | 2 | **Storm Drainage Ponds** |  | 2012-12-15 | 2013-05-23 |  |  |  |  |  |  |
| 1.4.2.4.4.010 |  | Excavation for storm water drainage pond(1) | 20d | 2012-12-15 | 2013-01-01 | 1.4.2.4.4.110A SS+5d | -156.25d | 0d | SSH-Construction Manhours [458.9 h] | 160,000 |  |
| 1.4.2.4.4.015 |  | Leveling - compactionfor drainage pond | 15d | 2013-01-02 | 2013-01-15 | 1.4.2.4.4.010 | -156.25d | 0d | SSH-Construction Manhours [2623.56 h] | 53,500 |  |
| 1.4.2.4.4.020 |  | Construction of RC spillways | 25d | 2013-01-16 | 2013-02-07 | 1.4.2.4.4.015 | -156.25d | 0d | SSH-Construction Manhours [2358.08 h] | 84,444 |  |
| 1.4.2.4.4.040 |  | Marl caping for drainage pond | 12.5d | 2013-02-09 | 2013-02-19 | 1.4.2.4.4.110B SS, 1.4.2.4.4.020 | -156.25d | 0d | SSH-Construction Manhours [1093.19 h] | 105,000 | 0.0177238036 |
| 1.4.2.4.4.050 |  | Excavation for storm water drainage pond(2) | 90d | 2013-02-20 | 2013-05-14 | 1.4.2.4.4.040 | -156.25d | 0d | SSH-Construction Manhours [476.91 h] | 160,000 |  |
| 1.4.2.4.4.060 |  | Leveling - compactionfor drainage pond | 15d | 2013-03-11 | 2013-03-24 | 1.4.2.4.4.050 SS+20d | -156.25d | 0d | SSH-Construction Manhours [262.3 h] | 53,500 |  |
| 1.4.2.4.4.070 |  | Construction of RC spillways | 40d | 2013-03-25 | 2013-04-30 | 1.4.2.4.4.060 | -156.25d | 0d | SSH-Construction Manhours [929.45 h] | 84,445 |  |
| 1.4.2.4.4.080 |  | Marl caping for drainage pond | 25d | 2013-05-01 | 2013-05-23 | 1.4.2.4.4.070 | -156.25d | 0d | SSH-Construction Manhours [263.89 h] | 105,000 |  |

| ID | WBS | Activity | Duration | Start | Finish | Predecessors | Complete | Remaining | Planned start | Planned finish | Total float | Free float | Resources | Cost | Actual cost | QTY |
| --- | --- | --- | --- | --- | --- | --- | --- | --- | --- | --- | --- | --- | --- | --- | --- | --- |
|  | 4 | **Road Networks** |  | 2011-01-28 | 2013-04-29 |  |  |  |  |  |  |  |  |  |  |  |
|  | 1 | **Fencing System & Gates** |  | 2011-01-28 | 2012-10-04 |  |  |  |  |  |  |  |  |  |  |  |
| 1.4.1.3.1.005 |  | Fabrication/Casting of Jersey Barriers | 1d | 2011-01-28 A | 2011-10-13 A | 1.4.1.1.110 SS | 100% |  | 2012-01-28 | 2012-01-28 |  |  | SSH-Construction Manhours [66624.3 h] |  |  |  |
| 1.4.1.3.1.010 |  | Install temp gate & jersey barriers for zone1 | 23.75d | 2011-01-31 A | 2011-02-20 A | 1.3.1.9.030 SS, 1.4.1.1.160, 1.3.1.10.030, 1.3.1.14.020 SS, 1.4.1.1.110 SS+5d | 100% |  | 2011-03-19 | 2011-04-09 |  |  | SSH-Construction Manhours [4335.76 h]; Truck Crane [190 ea]; Trailer [190 h]; Fork-Lifter [190 h] | 371,327.2 | 31,327.2 |  |
| 1.4.1.3.3.010 |  | Install temp gate & jersey barriers for zone3 | 50d | 2011-02-28 A | 2012-01-26 A | 1.4.1.3.2.010 SS | 100% |  | 2011-04-10 | 2011-05-25 |  |  | SSH-Construction Manhours [9182.3 h]; Truck Crane [520 ea]; Trailer [520 h]; Fork-Lifter [520 h] | 805,737.6 | 85,737.6 |  |
| 1.4.1.3.2.010 |  | Install temp gate & jersey barriers for zone2 | 75d | 2011-05-26 A | 2011-08-03 A | 1.4.1.3.1.010 SS | 100% |  |  |  |  |  | SSH-Construction Manhours [10839.8 h]; Truck Crane [600 ea]; Trailer [600 h]; Fork-Lifter [600 h] | 948,928 | 98,928 |  |
| 1.4.1.3.4.010 |  | Install temp gate & jersey barriers for zone4 | 43.75d | 2011-06-13 A | 2012-10-04 | 1.4.1.3.2.010 FF, 1.4.1.3.1.005 FF | 98% | 0.88d | 2011-06-13 | 2011-07-23 | -99.5d | 0d | SSH-Construction Manhours [4718.48 h]; Truck Crane [300 ea]; Trailer [300 h]; Fork-Lifter [300 h] | 419,464 | 48,474.72 | 0.109296789 |
|  | 2 | **Patrol Road works** |  | 2011-07-06 | 2012-10-16 |  |  |  |  |  |  |  |  |  |  |  |
| 1.4.2.5.2.010 |  | Install 200mm thk compacted Patrol Roads for Zone 1 | 31.25d | 2011-07-06 A | 2012-10-08 | 1.4.1.3.1.010 FS+93.75d | 84% | 5d | 2011-07-06 | 2011-08-03 | -122.06d | 0d | SSH-Construction Manhours [1179.99 h]; Grader [250 h]; Compactor [250 h] | 92,500 |  |  |
| 1.4.2.5.2.030 |  | Install 200mm thk compacted Patrol Roads for Zone 3 | 56.25d | 2011-07-14 A | 2011-09-04 A | 1.4.1.3.3.010 SS, 1.3.2.19.030 SS, 1.3.2.21.030 SS | 100% |  |  |  |  |  | SSH-Construction Manhours [7652.17 h]; Grader [450 h]; Compactor [450 h] | 600,000 |  |  |
| 1.4.2.5.2.020 |  | Install 200mm thk compacted Patrol Roads for Zone 2 | 56.25d | 2011-08-28 A | 2011-10-18 A | 1.4.1.3.2.010 SS | 100% |  |  |  |  |  | SSH-Construction Manhours [6376.68 h]; Grader [450 h]; Compactor [450 h] | 500,000 |  |  |
| 1.4.2.5.2.040 |  | Install 200mm thk compacted Patrol Roads for Zone 4 | 25d | 2011-09-14 A | 2012-10-16 | 1.4.2.5.2.020 SS | 48% | 13d | 2011-09-14 | 2011-10-06 | -172.25d | 0d | SSH-Construction Manhours [1402.81 h]; Grader [200 h]; Compactor [200 h] | 110,000 |  | 0.02135098 |
|  | 3 | **Asphalt Road Works A/B/C/D** |  | 2012-04-05 | 2013-04-29 |  |  |  |  |  |  |  |  |  |  |  |
| 1.4.2.5.3.010 |  | Site grading/clearing/grubbing | 37.5d | 2012-04-05 A | 2012-05-09 A | 1.4.2.5.2.040 SS | 100% |  |  |  |  |  | SSH-Construction Manhours [2168.25 h]; Grader [600 h]; Dump Truck [600 h] | 170,000 |  |  |
| 1.4.2.5.3.020 |  | Cut/fill of existing grade | 56.25d | 2012-04-29 A | 2012-10-07 | 1.4.2.5.3.010 FF+10d, 1.4.2.5.3.010 SS | 95% | 2.81d | 2012-04-29 | 2012-06-19 | -148.81d | 51.61d | SSH-Construction Manhours [5873.3 h]; Grader [600 h]; Dump Truck [600 h] | 460,536 |  | 0.1360408271 |
| 1.4.2.5.3.040 |  | Laying of geogrid | 75d | 2012-05-09 A | 2012-11-28 | 1.4.2.5.3.010 FF+150d, 1.3.1.3.030, 1.4.2.5.3.020 FF+5d | 21% | 59.42d | 2012-05-09 | 2012-07-18 | -200.42d | 0d | SSH-Construction Manhours [2208.22 h] | 115,125 |  |  |
| 1.4.2.5.3.050 |  | backfill with aggregate crushed stone | 75d | 2012-10-08 | 2012-12-17 | 1.4.2.5.3.040 FF+20d |  |  |  |  | -129.92d | 0d | SSH-Construction Manhours [11745.9 h]; Dump Truck [600 h]; Grader [600 h]; Compactor [600 h] | 921,000 |  |  |
| 1.4.2.5.3.060 |  | laying of Alyaf geotextile | 75d | 2012-10-27 | 2013-01-05 | 1.4.2.5.3.050 FF+20d |  |  |  |  | -129.92d | 0d | SSH-Construction Manhours [1174.81 h] | 92,100 |  |  |
| 1.4.2.5.3.070 |  | lay aggregate base course typeA | 75d | 2012-11-14 | 2013-01-23 | 1.4.2.5.3.060 FF+20d, 1.3.1.16.020 SS |  |  |  |  | -129.92d | 0d | SSH-Construction Manhours [5852.57 h]; Grader [600 h]; Dump Truck [600 h]; Compactor [600 h] | 458,928 |  |  |
| 1.4.2.5.3.080 |  | Install MC70 asphalt prime coat | 75d | 2012-12-13 | 2013-02-21 | 1.4.2.5.3.070 SS+31.25d |  |  |  |  | -129.92d | 0d | SSH-Construction Manhours [644.77 h]; Asphalt Machine [600 h] | 50,568 |  |  |
| 1.4.2.5.3.090 |  | Install asphalt concret binder class A | 75d | 2012-12-13 | 2013-02-21 | 1.4.2.5.3.080 SS |  |  |  |  | -129.92d | 0d | SSH-Construction Manhours [2232.65 h]; Asphalt Machine [600 h] | 175,080 |  |  |
| 1.4.2.5.3.100 |  | Install RC 250 asphalt tack coat | 75d | 2013-01-12 | 2013-03-23 | 1.4.2.5.3.090 SS+31.25d |  |  |  |  | -129.92d | 0d | SSH-Construction Manhours [13850.4 h]; Asphalt Machine [450 h] | 50,568 |  |  |
| 1.4.2.5.3.110 |  | Install asphalt concrt wear course class B | 75d | 2013-02-18 | 2013-04-29 | 1.4.2.5.3.100 FF+40d |  |  |  |  | -129.92d | 70.5d | SSH-Construction Manhours [13117.6 h]; Asphalt Machine [400 h] | 102,840 |  |  |
|  | 4 | **Curbs & gutters** |  | 2012-11-14 | 2013-04-17 |  |  |  |  |  |  |  |  |  |  |  |
| 1.4.2.5.4.010 |  | Install curb & gutter Zone3 - A3-1 | 60d | 2012-11-14 | 2013-01-09 | 1.4.2.5.3.070 SS, 1.3.1.6.030 |  |  |  |  | -117.42d | 0d | SSH-Construction Manhours [1850.67 h] | 130,000 |  |  |
| 1.4.2.5.4.020 |  | Install curb & gutter Zone3 - A3-2 | 60d | 2012-12-08 | 2013-02-02 | 1.4.2.5.4.010 FF+25d |  |  |  |  | -117.42d | 0d | SSH-Construction Manhours [1850.67 h] | 130,000 |  |  |
| 1.4.2.5.4.030 |  | Install curb & gutter Zone3 - A3-3 | 60d | 2012-12-31 | 2013-02-25 | 1.4.2.5.4.020 FF+25d |  |  |  |  | -117.42d | 0d | SSH-Construction Manhours [1850.67 h] | 130,000 |  |  |
| 1.4.2.5.4.040 |  | Install curb & gutter Zone2 - A2-1 | 60d | 2013-01-23 | 2013-03-20 | 1.4.2.5.4.030 FF+25d |  |  |  |  | -117.42d | 0d | SSH-Construction Manhours [675.87 h] | 130,000 |  |  |
| 1.4.2.5.4.050 |  | Install curb & gutter Zone2 - A2-2 | 60d | 2013-02-20 | 2013-04-17 | 1.4.2.5.4.040 FF+30d |  |  |  |  | -117.42d | 83d | SSH-Construction Manhours [1850.67 h] | 130,000 |  |  |

| ID | WBS | Activity | Duration | Start | Finish | Predecessors | Complete | Remaining | Planned start | Planned finish | Total float | Free float | Resources | Cost |
| --- | --- | --- | --- | --- | --- | --- | --- | --- | --- | --- | --- | --- | --- | --- |
|  | 5 | **Traffic Signage** |  | 2012-12-23 | 2013-04-07 |  |  |  |  |  |  |  |  |  |
| 1.4.2.5.6.010A |  | Install road markings Zone 3 - A3-1 | 30d | 2012-12-23 | 2013-01-20 | 1.4.2.5.3.090 SS+10d, 1.3.1.17.020 |  |  |  |  | -106.67d | 0d | SSH-Construction Manhours [421.95 h] | 33,074 |
| 1.4.2.5.6.010B |  | Install road markings Zone 3 - A3-2 | 30d | 2013-01-06 | 2013-02-03 | 1.4.2.5.6.010A FF+15d |  |  |  |  | -88.17d | 0d | SSH-Construction Manhours [421.95 h] | 33,073 |
| 1.4.2.5.6.020A |  | Install road signage with GI pipe post Zone3 - A3-1 | 30d | 2013-01-13 | 2013-02-10 | 1.4.2.5.6.010A FF+23d |  |  |  |  | -106.67d | 0d | SSH-Construction Manhours [96.24 h] | 8,000 |
| 1.4.2.5.6.010C |  | Install road markings Zone 3 - A3-3 | 30d | 2013-01-24 | 2013-02-21 | 1.4.2.5.6.010B FF+20d |  |  |  |  | -88.17d | 0d | SSH-Construction Manhours [421.95 h] | 33,073 |
| 1.4.2.5.6.020B |  | Install road signage with GI pipe post Zone3 - A3-2 | 30d | 2013-01-31 | 2013-02-28 | 1.4.2.5.6.020A FF+20d |  |  |  |  | -106.67d | 0d | SSH-Construction Manhours [96.24 h] | 8,000 |
| 1.4.2.5.6.020C |  | Install road signage with GI pipe post Zone3 - A3-3 | 30d | 2013-02-19 | 2013-03-19 | 1.4.2.5.6.020B FF+20d |  |  |  |  | -106.67d | 0d | SSH-Construction Manhours [96.24 h] | 8,000 |
| 1.4.2.5.6.010D |  | Install road markings Zone 2 | 30d | 2013-02-21 | 2013-03-21 | 1.4.2.5.6.010C |  |  |  |  | -88.17d | 113.83d | SSH-Construction Manhours [421.95 h] | 33,075 |
| 1.4.2.5.6.020D |  | Install road signage with GI pipe post Zone2 | 30d | 2013-03-10 | 2013-04-07 | 1.4.2.5.6.020C FF+20d |  |  |  |  | -106.67d | 93.75d | SSH-Construction Manhours [96.24 h] | 6,000 |
|  | 5 | **Landscaping & Hardscaping in Public Realm Area - Zone 3** |  | 2011-12-05 | 2013-07-03 |  |  |  |  |  |  |  |  |  |
|  | 1 | **Segment 1** |  | 2011-12-05 | 2013-04-20 |  |  |  |  |  |  |  |  |  |
| 1.4.2.6.1.010 |  | Site grading/clearing/grubbing | 20d | 2011-12-05 A | 2011-12-28 A | 1.4.2.5.2.040 SS | 100% |  | 2012-04-05 | 2012-04-23 |  |  | SSH-Construction Manhours [740.62 h]; Grader [600 h]; Dump Truck [600 h] | 35,634 |
| 1.4.2.6.1.020 |  | Leveling / Compaction upto desired level | 20d | 2011-12-15 A | 2012-01-25 A | 1.4.2.6.1.010 SS | 100% |  | 2011-12-15 | 2012-01-02 |  |  | SSH-Construction Manhours [1851.56 h] | 89,085 |
| 1.4.2.6.1.080 |  | Excavation of electric cable trench | 15d | 2012-03-08 A | 2012-11-07 | 1.4.2.6.1.070 FF+2d | 50% | 7.5d | 2012-03-08 | 2012-03-22 | -96d | 0d | SSH-Construction Manhours [1110.93 h] | 53,451 |
| 1.4.2.6.1.090 |  | Casting of electrical ductbanks | 15d | 2012-03-13 A | 2012-11-12 | 1.4.2.6.1.080 FF+5d | 50% | 7.5d | 2012-03-13 | 2012-03-27 | -96d | 0d | SSH-Construction Manhours [1851.56 h] | 89,085 |
| 1.4.2.6.1.130 |  | Excavation for Telecomm Trench | 15d | 2012-03-26 A | 2012-11-25 | 1.4.2.6.1.110 FF+5d | 75% | 3.75d | 2012-03-26 | 2012-04-09 | -96d | 0d | SSH-Construction Manhours [1110.93 h] | 53,451 |
| 1.4.2.6.1.140 |  | Casting of telecomm ductbanks | 20d | 2012-03-31 A | 2012-12-04 | 1.4.2.6.1.130 FF+10d | 65% | 7d | 2012-03-31 | 2012-04-18 | -96d | 0d | SSH-Construction Manhours [1851.56 h] | 89,085 |
| 1.4.2.6.1.030 |  | Excavation of water line / irrigation line trench | 15d | 2012-10-04 | 2012-10-17 | 1.4.2.6.1.020 FF |  |  |  |  | -187.25d | 0d | SSH-Construction Manhours [1110.93 h] | 53,451 |
| 1.4.2.6.1.040 |  | Installation of pipes & fittings | 15d | 2012-10-09 | 2012-10-22 | 1.4.2.6.1.030 FF+5d |  |  |  |  | -187.25d | 0d | SSH-Construction Manhours [5554.67 h] | 267,254 |
| 1.4.2.6.1.050 |  | Hydrotesting of pipes | 10d | 2012-10-23 | 2012-10-31 | 1.4.2.6.1.040 |  |  |  |  | -187.25d | 0d | SSH-Construction Manhours [740.62 h] | 35,634 |
| 1.4.2.6.1.070 |  | Backfilling | 10d | 2012-10-28 | 2012-11-05 | 1.4.2.6.1.050 FF+5d |  |  |  |  | -187.25d | 0d | SSH-Construction Manhours [370.31 h] | 17,817 |
| 1.4.2.6.1.100 |  | Install cables (LV, MV, Grounding, Irrigation) | 20d | 2012-10-29 | 2012-11-17 | 1.4.2.6.1.090 FF+5d |  |  |  |  | -96d | 0d | SSH-Construction Manhours [4443.74 h] | 213,803 |
| 1.4.2.6.1.110 |  | Backfilling | 10d | 2012-11-11 | 2012-11-20 | 1.4.2.6.1.100 FF+4d |  |  |  |  | -96d | 0d | SSH-Construction Manhours [370.31 h] | 17,817 |
| 1.4.2.6.1.160 |  | Backfilling | 10d | 2012-11-29 | 2012-12-09 | 1.4.2.6.1.140 FF+5d |  |  |  |  | -96d | 91.25d | SSH-Construction Manhours [370.31 h] | 17,817 |
| 1.4.2.6.1.180 |  | Laying of basecourse for bicycle segway & electric cart lane | 15d | 2013-03-04 | 2013-03-18 | 1.4.2.6.1.160, 1.4.2.6.5.160 |  |  |  |  | -187.25d | 0d | SSH-Construction Manhours [740.62 h] | 35,634 |
| 1.4.2.6.1.190 |  | Casting of curbs & gutters | 15d | 2013-03-09 | 2013-03-23 | 1.4.2.6.1.180 FF+5d |  |  |  |  | -120.25d | 0d | SSH-Construction Manhours [1110.93 h] | 53,451 |
| 1.4.2.6.1.060 |  | Install control valves sprinklers & accs | 15d | 2013-03-18 | 2013-04-01 | 1.4.2.6.1.050, 1.4.2.6.1.180 |  |  |  |  | -120.25d | 80.17d | SSH-Construction Manhours [1481.25 h] | 71,268 |
| 1.4.2.6.1.120 |  | Install solar globe lighting & package Substaion | 20d | 2013-03-18 | 2013-04-06 | 1.4.2.6.1.180 |  |  |  |  | -125.25d | 75.17d | SSH-Construction Manhours [740.62 h] | 35,634 |
| 1.4.2.6.1.150 |  | Pulling of subduct, copper cable & Fiber optic cable | 20d | 2013-03-18 | 2013-04-06 | 1.4.2.6.1.180 |  |  |  |  | -140.25d | 0d | SSH-Construction Manhours [4443.74 h] | 213,803 |
| 1.4.2.6.1.200 |  | Casting of concrete pavement | 10d | 2013-03-18 | 2013-03-27 | 1.4.2.6.1.190 FF+5d |  |  |  |  | -120.25d | 0d | SSH-Construction Manhours [1110.93 h] | 53,451 |
| 1.4.2.6.1.210 |  | Installation of walkways | 15d | 2013-03-18 | 2013-04-01 | 1.4.2.6.1.200 FF+5d |  |  |  |  | -120.25d | 0d | SSH-Construction Manhours [1481.25 h] | 71,268 |
| 1.4.2.6.1.220 |  | Install benches, signage & accs | 15d | 2013-03-23 | 2013-04-06 | 1.4.2.6.1.210 FF+5d, 1.3.1.22.020, 1.3.1.24.030 |  |  |  |  | -120.25d | 0d | SSH-Construction Manhours [370.31 h] | 17,817 |
| 1.4.2.6.1.230 |  | Install natural boulders | 15d | 2013-03-27 | 2013-04-10 | 1.4.2.6.1.220 FF+5d |  |  |  |  | -120.25d | 0d | SSH-Construction Manhours [1110.93 h] | 53,451 |
| 1.4.2.6.1.240 |  | Laying of gravel mulch | 15d | 2013-04-01 | 2013-04-15 | 1.4.2.6.1.230 FF+5d, 1.3.1.23.030 |  |  |  |  | -120.25d | 0d | SSH-Construction Manhours [740.62 h] | 35,634 |
| 1.4.2.6.1.170 |  | Installation of IPCCTV camera (Footings, poles & etc) | 15d | 2013-04-06 | 2013-04-20 | 1.4.2.6.1.150 |  |  |  |  | -140.25d | 0d | SSH-Construction Manhours [1481.25 h] | 71,268 |
| 1.4.2.6.1.250 |  | Planting of shrubs & trees | 15d | 2013-04-06 | 2013-04-20 | 1.4.2.6.1.240 FF+5d, 1.4.2.6.1.170 FF |  |  |  |  | -120.25d | 80.17d | SSH-Construction Manhours [603.11 h] | 30,609 |

| ID | WBS | Activity | Duration | Start | Finish | Predecessors | Complete | Remaining | Planned start | Planned finish | Total float | Free float | Resources | Cost |
| --- | --- | --- | --- | --- | --- | --- | --- | --- | --- | --- | --- | --- | --- | --- |
|  | 2 | **Segment 2** |  | 2011-12-05 | 2013-05-04 |  |  |  |  |  |  |  |  |  |
| 1.4.2.6.2.010 |  | Site grading/clearing/grubbing | 20d | 2011-12-05 A | 2011-12-28 A | 1.4.2.6.1.010 SS | 100% |  | 2012-04-05 | 2012-04-23 |  |  | SSH-Construction Manhours [740.62 h]; Grader [600 h]; Dump Truck [600 h] | 35,634 |
| 1.4.2.6.2.020 |  | Leveling / Compaction upto desired level | 20d | 2011-12-15 A | 2012-01-25 A | 1.4.2.6.2.010 SS | 100% |  | 2011-12-15 | 2012-01-02 |  |  | SSH-Construction Manhours [1851.56 h] | 89,085 |
| 1.4.2.6.2.030 |  | Excavation of water line / irrigation line trench | 15d | 2012-03-21 A | 2012-11-15 | 1.4.2.6.2.020 FF, 1.4.2.6.1.070 | 25% | 11.25d | 2012-03-21 | 2012-04-03 | -187.25d | 0d | SSH-Construction Manhours [1110.93 h] | 53,451 |
| 1.4.2.6.2.080 |  | Excavation of electric cable trench | 15d | 2012-04-10 A | 2012-04-24 A | 1.4.2.6.2.070 FF+2d | 100% |  |  |  |  |  | SSH-Construction Manhours [1110.93 h] | 53,451 |
| 1.4.2.6.2.130 |  | Excavation for Telecomm Trench | 15d | 2012-04-28 A | 2012-05-12 A | 1.4.2.6.2.110 FF+5d | 100% |  |  |  |  |  | SSH-Construction Manhours [1110.93 h] | 53,451 |
| 1.4.2.6.2.140 |  | Casting of telecomm ductbanks | 20d | 2012-05-02 A | 2012-05-21 A | 1.4.2.6.2.130 FF+10d | 100% |  |  |  |  |  | SSH-Construction Manhours [1851.56 h] | 89,085 |
| 1.4.2.6.2.160 |  | Backfilling | 10d | 2012-05-16 A | 2012-12-19 | 1.4.2.6.2.140 FF+5d | 20% | 8d | 2012-05-16 | 2012-05-26 | -92.25d | 95d | SSH-Construction Manhours [370.31 h] | 17,817 |
| 1.4.2.6.2.040 |  | Installation of pipes & fittings | 15d | 2012-11-07 | 2012-11-20 | 1.4.2.6.2.030 FF+5d |  |  |  |  | -187.25d | 0d | SSH-Construction Manhours [5554.67 h] | 267,254 |
| 1.4.2.6.2.050 |  | Hydrotesting of pipes | 10d | 2012-11-21 | 2012-11-29 | 1.4.2.6.2.040 |  |  |  |  | -187.25d | 0d | SSH-Construction Manhours [740.62 h] | 35,634 |
| 1.4.2.6.2.090 |  | Casting of electrical ductbanks | 15d | 2012-11-22 | 2012-12-06 | 1.4.2.6.2.080 FF+5d |  |  |  |  | -92.25d | 0d | SSH-Construction Manhours [1851.56 h] | 89,085 |
| 1.4.2.6.2.100 |  | Install cables (LV, MV, Grounding, Irrigation) | 20d | 2012-11-22 | 2012-12-11 | 1.4.2.6.2.090 FF+5d |  |  |  |  | -92.25d | 0d | SSH-Construction Manhours [4443.74 h] | 213,803 |
| 1.4.2.6.2.070 |  | Backfilling | 10d | 2012-11-26 | 2012-12-04 | 1.4.2.6.2.050 FF+5d |  |  |  |  | -92.25d | 0d | SSH-Construction Manhours [370.31 h] | 17,817 |
| 1.4.2.6.2.110 |  | Backfilling | 10d | 2012-12-05 | 2012-12-15 | 1.4.2.6.2.100 FF+4d |  |  |  |  | -92.25d | 0d | SSH-Construction Manhours [370.31 h] | 17,817 |
| 1.4.2.6.2.180 |  | Laying of basecourse for bicycle segway & electric cart lane | 15d | 2013-03-18 | 2013-04-01 | 1.4.2.6.2.160, 1.4.2.6.1.180 |  |  |  |  | -187.25d | 0d | SSH-Construction Manhours [740.62 h] | 35,634 |
| 1.4.2.6.2.190 |  | Casting of curbs & gutters | 15d | 2013-03-23 | 2013-04-06 | 1.4.2.6.2.180 FF+5d |  |  |  |  | -135.25d | 0d | SSH-Construction Manhours [1110.93 h] | 53,451 |
| 1.4.2.6.2.060 |  | Install control valves sprinklers & accs | 15d | 2013-04-01 | 2013-04-15 | 1.4.2.6.2.180, 1.4.2.6.2.050 |  |  |  |  | -135.25d | 65.17d | SSH-Construction Manhours [1481.25 h] | 71,268 |
| 1.4.2.6.2.120 |  | Install solar globe lighting & package Substaion | 20d | 2013-04-01 | 2013-04-20 | 1.4.2.6.2.180 |  |  |  |  | -140.25d | 60.17d | SSH-Construction Manhours [740.62 h] | 35,634 |
| 1.4.2.6.2.150 |  | Pulling of subduct, copper cable & Fiber optic cable | 20d | 2013-04-01 | 2013-04-20 | 1.4.2.6.2.180 |  |  |  |  | -140.25d | 60.17d | SSH-Construction Manhours [4443.74 h] | 213,803 |
| 1.4.2.6.2.170 |  | Installation of IPCCTV camera (Footings, poles & etc) | 15d | 2013-04-01 | 2013-04-15 | 1.4.2.6.2.180 |  |  |  |  | -115.25d | 20d | SSH-Construction Manhours [1481.25 h] | 71,268 |
| 1.4.2.6.2.200 |  | Casting of concrete pavement | 10d | 2013-04-01 | 2013-04-10 | 1.4.2.6.2.190 FF+5d |  |  |  |  | -135.25d | 0d | SSH-Construction Manhours [1110.93 h] | 53,451 |
| 1.4.2.6.2.210 |  | Installation of walkways | 15d | 2013-04-01 | 2013-04-15 | 1.4.2.6.2.200 FF+5d |  |  |  |  | -135.25d | 0d | SSH-Construction Manhours [1481.25 h] | 71,268 |
| 1.4.2.6.2.220 |  | Install benches, signage & accs | 15d | 2013-04-06 | 2013-04-20 | 1.4.2.6.2.210 FF+5d |  |  |  |  | -135.25d | 0d | SSH-Construction Manhours [370.31 h] | 17,817 |
| 1.4.2.6.2.230 |  | Install natural boulders | 15d | 2013-04-10 | 2013-04-24 | 1.4.2.6.2.220 FF+5d |  |  |  |  | -135.25d | 0d | SSH-Construction Manhours [1110.93 h] | 53,451 |
| 1.4.2.6.2.240 |  | Laying of gravel mulch | 15d | 2013-04-15 | 2013-04-29 | 1.4.2.6.2.230 FF+5d |  |  |  |  | -135.25d | 0d | SSH-Construction Manhours [740.62 h] | 35,634 |
| 1.4.2.6.2.250 |  | Planting of shrubs & trees | 15d | 2013-04-20 | 2013-05-04 | 1.4.2.6.2.240 FF+5d, 1.4.2.6.2.170 FF |  |  |  |  | -135.25d | 65.17d | SSH-Construction Manhours [603.11 h] | 30,609 |

| ID | WBS | Activity | Duration | Start | Finish | Predecessors | Complete | Remaining | Planned start | Planned finish | Total float | Free float | Resources | Cost |
| --- | --- | --- | --- | --- | --- | --- | --- | --- | --- | --- | --- | --- | --- | --- |
|  | 3 | **Segment 3** |  | 2012-04-18 | 2013-05-18 |  |  |  |  |  |  |  |  |  |
| 1.4.2.6.3.010 |  | Site grading/clearing/grubbing | 20d | 2012-04-18 A | 2012-05-06 A | 1.4.2.6.2.050 | 100% |  |  |  |  |  | SSH-Construction Manhours [740.62 h]; Grader [600 h]; Dump Truck [600 h] | 35,634 |
| 1.4.2.6.3.020 |  | Leveling / Compaction upto desired level | 20d | 2012-04-28 A | 2012-05-15 A | 1.4.2.6.3.010 FF+10d | 100% |  |  |  |  |  | SSH-Construction Manhours [1851.56 h] | 89,085 |
| 1.4.2.6.3.030 |  | Excavation of water line / irrigation line trench | 15d | 2012-05-02 A | 2012-05-15 A | 1.4.2.6.3.020 FF | 100% |  |  |  |  |  | SSH-Construction Manhours [1110.93 h] | 53,451 |
| 1.4.2.6.3.040 |  | Installation of pipes & fittings | 15d | 2012-05-07 A | 2012-11-29 | 1.4.2.6.3.030 FF+5d | 57% | 6.45d | 2012-05-07 | 2012-05-20 | -187.25d | 0d | SSH-Construction Manhours [5554.67 h] | 267,254 |
| 1.4.2.6.3.080 |  | Excavation of electric cable trench | 15d | 2012-05-22 A | 2012-06-05 A | 1.4.2.6.3.070 FF+2d | 100% |  |  |  |  |  | SSH-Construction Manhours [1110.93 h] | 53,451 |
| 1.4.2.6.3.070 |  | Backfilling | 10d | 2012-05-26 A | 2012-12-13 | 1.4.2.6.3.050 FF+5d | 25% | 7.5d | 2012-05-26 | 2012-06-03 | -87.25d | 0d | SSH-Construction Manhours [370.31 h] | 17,817 |
| 1.4.2.6.3.130 |  | Excavation for Telecomm Trench | 15d | 2012-06-09 A | 2012-06-23 A | 1.4.2.6.3.110 FF+5d | 100% |  |  |  |  |  | SSH-Construction Manhours [1110.93 h] | 53,451 |
| 1.4.2.6.3.140 |  | Casting of telecomm ductbanks | 20d | 2012-06-13 A | 2012-07-02 A | 1.4.2.6.3.130 FF+10d | 100% |  |  |  |  |  | SSH-Construction Manhours [1851.56 h] | 89,085 |
| 1.4.2.6.3.050 |  | Hydrotesting of pipes | 10d | 2012-12-01 | 2012-12-09 | 1.4.2.6.3.040 |  |  |  |  | -187.25d | 0d | SSH-Construction Manhours [740.62 h] | 35,634 |
| 1.4.2.6.3.090 |  | Casting of electrical ductbanks | 15d | 2012-12-02 | 2012-12-16 | 1.4.2.6.3.080 FF+5d |  |  |  |  | -87.25d | 0d | SSH-Construction Manhours [1851.56 h] | 89,085 |
| 1.4.2.6.3.100 |  | Install cables (LV, MV, Grounding, Irrigation) | 20d | 2012-12-02 | 2012-12-20 | 1.4.2.6.3.090 FF+5d |  |  |  |  | -87.25d | 0d | SSH-Construction Manhours [4443.74 h] | 213,803 |
| 1.4.2.6.3.110 |  | Backfilling | 10d | 2012-12-15 | 2012-12-24 | 1.4.2.6.3.100 FF+4d |  |  |  |  | -87.25d | 0d | SSH-Construction Manhours [370.31 h] | 17,817 |
| 1.4.2.6.3.160 |  | Backfilling | 10d | 2012-12-19 | 2012-12-29 | 1.4.2.6.3.140 FF+5d |  |  |  |  | -87.25d | 100d | SSH-Construction Manhours [370.31 h] | 17,817 |
| 1.4.2.6.3.180 |  | Laying of basecourse for bicycle segway & electric cart lane | 15d | 2013-04-01 | 2013-04-15 | 1.4.2.6.3.160, 1.4.2.6.2.180 |  |  |  |  | -187.25d | 0d | SSH-Construction Manhours [740.62 h] | 35,634 |
| 1.4.2.6.3.190 |  | Casting of curbs & gutters | 15d | 2013-04-06 | 2013-04-20 | 1.4.2.6.3.180 FF+5d |  |  |  |  | -150.25d | 0d | SSH-Construction Manhours [1110.93 h] | 53,451 |
| 1.4.2.6.3.060 |  | Install control valves sprinklers & accs | 15d | 2013-04-15 | 2013-04-29 | 1.4.2.6.3.180, 1.4.2.6.3.050 |  |  |  |  | -150.25d | 50.17d | SSH-Construction Manhours [1481.25 h] | 71,268 |
| 1.4.2.6.3.120 |  | Install solar globe lighting & package Substaion | 20d | 2013-04-15 | 2013-05-04 | 1.4.2.6.3.180 |  |  |  |  | -155.25d | 45.17d | SSH-Construction Manhours [740.62 h] | 35,634 |
| 1.4.2.6.3.150 |  | Pulling of subduct, copper cable & Fiber optic cable | 20d | 2013-04-15 | 2013-05-04 | 1.4.2.6.3.180 |  |  |  |  | -155.25d | 45.17d | SSH-Construction Manhours [4443.74 h] | 213,803 |
| 1.4.2.6.3.170 |  | Installation of IPCCTV camera (Footings, poles & etc) | 15d | 2013-04-15 | 2013-04-29 | 1.4.2.6.3.180 |  |  |  |  | -130.25d | 20d | SSH-Construction Manhours [1481.25 h] | 71,268 |
| 1.4.2.6.3.200 |  | Casting of concrete pavement | 10d | 2013-04-15 | 2013-04-24 | 1.4.2.6.3.190 FF+5d |  |  |  |  | -150.25d | 0d | SSH-Construction Manhours [1110.93 h] | 53,451 |
| 1.4.2.6.3.210 |  | Installation of walkways | 15d | 2013-04-15 | 2013-04-29 | 1.4.2.6.3.200 FF+5d |  |  |  |  | -150.25d | 0d | SSH-Construction Manhours [1481.25 h] | 71,268 |
| 1.4.2.6.3.220 |  | Install benches, signage & accs | 15d | 2013-04-20 | 2013-05-04 | 1.4.2.6.3.210 FF+5d |  |  |  |  | -150.25d | 0d | SSH-Construction Manhours [370.31 h] | 17,817 |
| 1.4.2.6.3.230 |  | Install natural boulders | 15d | 2013-04-24 | 2013-05-08 | 1.4.2.6.3.220 FF+5d |  |  |  |  | -150.25d | 0d | SSH-Construction Manhours [1110.93 h] | 53,451 |
| 1.4.2.6.3.240 |  | Laying of gravel mulch | 15d | 2013-04-29 | 2013-05-13 | 1.4.2.6.3.230 FF+5d |  |  |  |  | -150.25d | 0d | SSH-Construction Manhours [740.62 h] | 35,634 |
| 1.4.2.6.3.250 |  | Planting of shrubs & trees | 15d | 2013-05-04 | 2013-05-18 | 1.4.2.6.3.240 FF+5d, 1.4.2.6.3.170 FF |  |  |  |  | -150.25d | 50.17d | SSH-Construction Manhours [603.11 h] | 30,609 |

| ID | WBS | Activity | Duration | Start | Finish | Predecessors | Complete | Remaining | Planned start | Planned finish | Total float | Free float | Resources | Cost |
| --- | --- | --- | --- | --- | --- | --- | --- | --- | --- | --- | --- | --- | --- | --- |
|  | 4 | **Segment 4** |  | 2012-05-21 | 2013-06-01 |  |  |  |  |  |  |  |  |  |
| 1.4.2.6.4.010 |  | Site grading/clearing/grubbing | 20d | 2012-05-21 A | 2012-06-07 A | 1.4.2.6.3.050 FF+10d | 100% |  |  |  |  |  | SSH-Construction Manhours [740.62 h]; Grader [600 h]; Dump Truck [600 h] | 35,634 |
| 1.4.2.6.4.020 |  | Leveling / Compaction upto desired level | 20d | 2012-05-30 A | 2012-06-17 A | 1.4.2.6.4.010 FF+10d | 100% |  |  |  |  |  | SSH-Construction Manhours [1851.56 h] | 89,085 |
| 1.4.2.6.4.030 |  | Excavation of water line / irrigation line trench | 15d | 2012-06-04 A | 2012-12-18 | 1.4.2.6.4.020 FF | 40% | 9d | 2012-06-04 | 2012-06-17 | -187.25d | 0d | SSH-Construction Manhours [1110.93 h] | 53,451 |
| 1.4.2.6.4.040 |  | Installation of pipes & fittings | 15d | 2012-06-09 A | 2012-12-23 | 1.4.2.6.4.030 FF+5d | 20% | 12d | 2012-06-09 | 2012-06-21 | -187.25d | 0d | SSH-Construction Manhours [5554.67 h] | 267,254 |
| 1.4.2.6.4.080 |  | Excavation of electric cable trench | 15d | 2012-06-24 A | 2013-01-08 | 1.4.2.6.4.070 FF+2d | 35% | 9.75d | 2012-06-24 | 2012-07-08 | -117.25d | 0d | SSH-Construction Manhours [1110.93 h] | 53,451 |
| 1.4.2.6.4.070 |  | Backfilling | 10d | 2012-06-27 A | 2013-01-06 | 1.4.2.6.4.050 FF+5d | 1% | 9.9d | 2012-06-27 | 2012-07-05 | -117.25d | 0d | SSH-Construction Manhours [370.31 h] | 17,817 |
| 1.4.2.6.4.090 |  | Casting of electrical ductbanks | 15d | 2012-06-28 A | 2013-01-13 | 1.4.2.6.4.080 FF+5d | 35% | 9.75d | 2012-06-28 | 2012-07-12 | -117.25d | 0d | SSH-Construction Manhours [1851.56 h] | 89,085 |
| 1.4.2.6.4.110 |  | Backfilling | 10d | 2012-07-11 A | 2013-01-21 | 1.4.2.6.4.100 FF+4d | 15% | 8.5d | 2012-07-11 | 2012-07-21 | -117.25d | 0d | SSH-Construction Manhours [370.31 h] | 17,817 |
| 1.4.2.6.4.130 |  | Excavation for Telecomm Trench | 15d | 2012-07-11 A | 2013-01-26 | 1.4.2.6.4.110 FF+5d | 35% | 9.75d | 2012-07-11 | 2012-07-25 | -117.25d | 0d | SSH-Construction Manhours [1110.93 h] | 53,451 |
| 1.4.2.6.4.140 |  | Casting of telecomm ductbanks | 20d | 2012-07-16 A | 2013-02-04 | 1.4.2.6.4.130 FF+10d | 35% | 13d | 2012-07-16 | 2012-08-04 | -117.25d | 0d | SSH-Construction Manhours [1851.56 h] | 89,085 |
| 1.4.2.6.4.050 |  | Hydrotesting of pipes | 10d | 2012-12-24 | 2013-01-01 | 1.4.2.6.4.040 |  |  |  |  | -187.25d | 0d | SSH-Construction Manhours [740.62 h] | 35,634 |
| 1.4.2.6.4.100 |  | Install cables (LV, MV, Grounding, Irrigation) | 20d | 2012-12-30 | 2013-01-17 | 1.4.2.6.4.090 FF+5d |  |  |  |  | -117.25d | 0d | SSH-Construction Manhours [4443.74 h] | 213,803 |
| 1.4.2.6.4.160 |  | Backfilling | 10d | 2013-01-30 | 2013-02-09 | 1.4.2.6.4.140 FF+5d |  |  |  |  | -117.25d | 70d | SSH-Construction Manhours [370.31 h] | 17,817 |
| 1.4.2.6.4.180 |  | Laying of basecourse for bicycle segway & electric cart lane | 15d | 2013-04-15 | 2013-04-29 | 1.4.2.6.4.160, 1.4.2.6.3.180 |  |  |  |  | -187.25d | 0d | SSH-Construction Manhours [740.62 h] | 35,634 |
| 1.4.2.6.4.190 |  | Casting of curbs & gutters | 15d | 2013-04-20 | 2013-05-04 | 1.4.2.6.4.180 FF+5d |  |  |  |  | -165.25d | 0d | SSH-Construction Manhours [1110.93 h] | 53,451 |
| 1.4.2.6.4.060 |  | Install control valves sprinklers & accs | 15d | 2013-04-29 | 2013-05-13 | 1.4.2.6.4.180, 1.4.2.6.4.050 |  |  |  |  | -165.25d | 35.17d | SSH-Construction Manhours [1481.25 h] | 71,268 |
| 1.4.2.6.4.120 |  | Install solar globe lighting & package Substaion | 20d | 2013-04-29 | 2013-05-18 | 1.4.2.6.4.180 |  |  |  |  | -170.25d | 30.17d | SSH-Construction Manhours [740.62 h] | 35,634 |
| 1.4.2.6.4.150 |  | Pulling of subduct, copper cable & Fiber optic cable | 20d | 2013-04-29 | 2013-05-18 | 1.4.2.6.4.180 |  |  |  |  | -170.25d | 30.17d | SSH-Construction Manhours [4443.74 h] | 213,803 |
| 1.4.2.6.4.170 |  | Installation of IPCCTV camera (Footings, poles & etc) | 15d | 2013-04-29 | 2013-05-13 | 1.4.2.6.4.180 |  |  |  |  | -145.25d | 20d | SSH-Construction Manhours [1481.25 h] | 71,268 |
| 1.4.2.6.4.200 |  | Casting of concrete pavement | 10d | 2013-04-29 | 2013-05-08 | 1.4.2.6.4.190 FF+5d |  |  |  |  | -165.25d | 0d | SSH-Construction Manhours [1110.93 h] | 53,451 |
| 1.4.2.6.4.210 |  | Installation of walkways | 15d | 2013-04-29 | 2013-05-13 | 1.4.2.6.4.200 FF+5d |  |  |  |  | -165.25d | 0d | SSH-Construction Manhours [1481.25 h] | 71,268 |
| 1.4.2.6.4.220 |  | Install benches, signage & accs | 15d | 2013-05-04 | 2013-05-18 | 1.4.2.6.4.210 FF+5d |  |  |  |  | -165.25d | 0d | SSH-Construction Manhours [370.31 h] | 17,817 |
| 1.4.2.6.4.230 |  | Install natural boulders | 15d | 2013-05-08 | 2013-05-22 | 1.4.2.6.4.220 FF+5d |  |  |  |  | -165.25d | 0d | SSH-Construction Manhours [1110.93 h] | 53,451 |
| 1.4.2.6.4.240 |  | Laying of gravel mulch | 15d | 2013-05-13 | 2013-05-27 | 1.4.2.6.4.230 FF+5d |  |  |  |  | -165.25d | 0d | SSH-Construction Manhours [740.62 h] | 35,634 |
| 1.4.2.6.4.250 |  | Planting of shrubs & trees | 15d | 2013-05-18 | 2013-06-01 | 1.4.2.6.4.240 FF+5d, 1.4.2.6.4.170 FF |  |  |  |  | -165.25d | 35.17d | SSH-Construction Manhours [603.11 h] | 30,634 |

| ID | WBS | Activity | Duration | Start | Finish | Predecessors | Complete | Remaining | Planned start | Planned finish | Total float | Free float | Resources | Cost |
| --- | --- | --- | --- | --- | --- | --- | --- | --- | --- | --- | --- | --- | --- | --- |
|  | 5 | **Segment 5** |  | 2012-06-23 | 2013-07-03 |  |  |  |  |  |  |  |  |  |
| 1.4.2.6.5.010 |  | Site grading/clearing/grubbing | 20d | 2012-06-23 A | 2012-07-10 A | 1.4.2.6.4.050 FF+10d | 100% |  |  |  |  |  | SSH-Construction Manhours [740.62 h]; Grader [600 h]; Dump Truck [600 h] | 35,634 |
| 1.4.2.6.5.020 |  | Leveling / Compaction upto desired level | 20d | 2012-07-02 A | 2013-01-10 | 1.4.2.6.5.010 FF+10d | 15% | 17d | 2012-07-02 | 2012-07-19 | -187.25d | 0d | SSH-Construction Manhours [1851.56 h] | 89,085 |
| 1.4.2.6.5.050 |  | Hydrotesting of pipes | 10d | 2012-07-25 A | 2013-01-24 | 1.4.2.6.5.040 |  | 10d | 2012-07-25 | 2012-08-02 | -187.25d | 0d | SSH-Construction Manhours [740.62 h] | 35,634 |
| 1.4.2.6.5.160 |  | Backfilling | 10d | 2012-09-01 A | 2013-03-04 | 1.4.2.6.5.140 FF+5d |  | 10d | 2012-09-01 | 2012-09-10 | -187.25d | 0d | SSH-Construction Manhours [370.31 h] | 17,817 |
| 1.4.2.6.5.030 |  | Excavation of water line / irrigation line trench | 15d | 2012-12-29 | 2013-01-10 | 1.4.2.6.5.020 FF |  |  |  |  | -187.25d | 0d | SSH-Construction Manhours [1110.93 h] | 53,451 |
| 1.4.2.6.5.040 |  | Installation of pipes & fittings | 15d | 2013-01-02 | 2013-01-15 | 1.4.2.6.5.030 FF+5d |  |  |  |  | -187.25d | 0d | SSH-Construction Manhours [5554.67 h] | 267,254 |
| 1.4.2.6.5.080 |  | Excavation of electric cable trench | 15d | 2013-01-17 | 2013-01-31 | 1.4.2.6.5.070 FF+2d |  |  |  |  | -187.25d | 0d | SSH-Construction Manhours [1110.93 h] | 53,451 |
| 1.4.2.6.5.070 |  | Backfilling | 10d | 2013-01-21 | 2013-01-29 | 1.4.2.6.5.050 FF+5d |  |  |  |  | -187.25d | 0d | SSH-Construction Manhours [370.31 h] | 17,817 |
| 1.4.2.6.5.090 |  | Casting of electrical ductbanks | 15d | 2013-01-22 | 2013-02-05 | 1.4.2.6.5.080 FF+5d |  |  |  |  | -187.25d | 0d | SSH-Construction Manhours [1851.56 h] | 89,085 |
| 1.4.2.6.5.100 |  | Install cables (LV, MV, Grounding, Irrigation) | 20d | 2013-01-22 | 2013-02-10 | 1.4.2.6.5.090 FF+5d |  |  |  |  | -187.25d | 0d | SSH-Construction Manhours [4443.74 h] | 213,803 |
| 1.4.2.6.5.110 |  | Backfilling | 10d | 2013-02-04 | 2013-02-13 | 1.4.2.6.5.100 FF+4d |  |  |  |  | -187.25d | 0d | SSH-Construction Manhours [370.31 h] | 17,817 |
| 1.4.2.6.5.130 |  | Excavation for Telecomm Trench | 15d | 2013-02-04 | 2013-02-18 | 1.4.2.6.5.110 FF+5d |  |  |  |  | -187.25d | 0d | SSH-Construction Manhours [1110.93 h] | 53,451 |
| 1.4.2.6.5.140 |  | Casting of telecomm ductbanks | 20d | 2013-02-09 | 2013-02-27 | 1.4.2.6.5.130 FF+10d |  |  |  |  | -187.25d | 0d | SSH-Construction Manhours [1851.56 h] | 89,085 |
| 1.4.2.6.5.180 |  | Laying of basecourse for bicycle segway & electric cart lane | 15d | 2013-04-29 | 2013-05-13 | 1.4.2.6.5.160, 1.4.2.6.4.180 |  |  |  |  | -187.25d | 0d | SSH-Construction Manhours [740.62 h] | 35,634 |
| 1.4.2.6.5.190 |  | Casting of curbs & gutters | 15d | 2013-05-04 | 2013-05-18 | 1.4.2.6.5.180 FF+5d |  |  |  |  | -187.25d | 0d | SSH-Construction Manhours [1110.93 h] | 53,451 |
| 1.4.2.6.5.060 |  | Install control valves sprinklers & accs | 15d | 2013-05-13 | 2013-05-27 | 1.4.2.6.5.180 |  |  |  |  | -180.25d | 20.17d | SSH-Construction Manhours [1481.25 h] | 71,268 |
| 1.4.2.6.5.120 |  | Install solar globe lighting & package Substaion | 20d | 2013-05-13 | 2013-06-01 | 1.4.2.6.5.180 |  |  |  |  | -185.25d | 15.17d | SSH-Construction Manhours [740.62 h] | 35,634 |
| 1.4.2.6.5.150 |  | Pulling of subduct, copper cable & Fiber optic cable | 20d | 2013-05-13 | 2013-06-01 | 1.4.2.6.5.180 |  |  |  |  | -185.25d | 15.17d | SSH-Construction Manhours [4443.74 h] | 213,803 |
| 1.4.2.6.5.170 |  | Installation of IPCCTV camera (Footings, poles & etc) | 15d | 2013-05-13 | 2013-05-27 | 1.4.2.6.5.180 |  |  |  |  | -167.25d | 20d | SSH-Construction Manhours [1481.25 h] | 71,268 |
| 1.4.2.6.5.200 |  | Casting of concrete pavement | 10d | 2013-05-13 | 2013-05-22 | 1.4.2.6.5.190 FF+5d |  |  |  |  | -187.25d | 0d | SSH-Construction Manhours [1110.93 h] | 53,451 |
| 1.4.2.6.5.210 |  | Installation of walkways | 15d | 2013-05-13 | 2013-05-27 | 1.4.2.6.5.200 FF+5d |  |  |  |  | -187.25d | 0d | SSH-Construction Manhours [1481.25 h] | 71,268 |
| 1.4.2.6.5.220 |  | Install benches, signage & accs | 15d | 2013-05-18 | 2013-06-01 | 1.4.2.6.5.210 FF+5d |  |  |  |  | -187.25d | 0d | SSH-Construction Manhours [370.31 h] | 17,817 |
| 1.4.2.6.5.230 |  | Install natural boulders | 15d | 2013-05-22 | 2013-06-05 | 1.4.2.6.5.220 FF+5d |  |  |  |  | -187.25d | 0d | SSH-Construction Manhours [1110.93 h] | 53,451 |
| 1.4.2.6.5.240 |  | Laying of gravel mulch | 15d | 2013-05-27 | 2013-06-10 | 1.4.2.6.5.230 FF+5d |  |  |  |  | -187.25d | 0d | SSH-Construction Manhours [740.62 h] | 35,634 |
| 1.4.2.6.5.250 |  | Planting of shrubs & trees | 15d | 2013-06-01 | 2013-06-15 | 1.4.2.6.5.240 FF+5d, 1.4.2.6.5.170 FF |  |  |  |  | -187.25d | 13.17d | SSH-Construction Manhours [603.11 h] | 35,634 |
| 1.4.2.6.5.260 |  | Testing & Commissioning all works - Public Realm Area | 20d | 2013-06-15 | 2013-07-03 | 1.4.2.6.5.250 FF+7d, 1.4.2.6.1.060, 1.4.2.6.1.120, 1.4.2.6.1.170, 1.4.2.6.2.060, 1.4.2.6.2.120, 1.4.2.6.2.150, 1.4.2.6.3.060, 1.4.2.6.3.120, 1.4.2.6.3.150, 1.4.2.6.4.060, 1.4.2.6.4.120, 1.4.2.6.4.150, 1.4.2.6.5.060, 1.4.2.6.5.120, 1.4.2.6.5.150, 1.4.2.7.3.050 |  |  |  |  | -200.42d | 0d | SSH-Construction Manhours [1887.74 h] | 20,050 |

| ID | WBS | Activity | Duration | Start | Finish | Predecessors | Complete | Remaining | Planned start | Planned finish | Total float | Free float | Resources | Cost | QTY |
| --- | --- | --- | --- | --- | --- | --- | --- | --- | --- | --- | --- | --- | --- | --- | --- |
|  | 6 | **Power Distribution** |  | 2011-08-14 | 2013-06-15 |  |  |  |  |  |  |  |  |  |  |
|  | 01 | **MV Cables** |  | 2011-12-03 | 2013-01-30 |  |  |  |  |  |  |  |  |  |  |
|  | 1 | **DuctBanks** |  | 2011-12-28 | 2013-01-30 |  |  |  |  |  |  |  |  |  |  |
| 1.4.2.7.1.010 |  | Excavation of trench for Ductbanks | 90d | 2011-12-28 A | 2012-04-02 A | Z3.2180 SS | 100% |  | 2011-12-28 | 2012-03-20 |  |  | SSH-Construction Manhours [4281.07 h]; Excavator [250 h]; Dump Truck [250 h] | 54,885 |  |
| 1.4.2.7.1.050 |  | Construction of ductbanks | 90d | 2012-01-17 A | 2012-04-09 A | 1.4.2.7.1.010 FF+10d, 1.3.2.18.030 SS | 100% |  |  |  |  |  | SSH-Construction Manhours [3011.51 h] | 225,000 |  |
| 1.4.2.7.1.060 |  | Splice/hi-pot/termintaion of MV cables | 25d | 2012-06-04 A | 2012-11-06 | 1.4.2.7.510 | 75% | 6.25d | 2012-06-04 | 2012-06-26 | -15.05d | 82.45d | SSH-Construction Manhours [1505.75 h] | 250,000 |  |
| 1.4.2.7.1.080 |  | Backfilling of MV cables | 90d | 2012-10-04 | 2012-12-26 | 1.4.2.7.1.050 FF+35d |  |  |  |  | -75d | 22.5d | SSH-Construction Manhours [2258.63 h]; Dump Truck [300 h] | 205,000 | 0.060556329 |
| 1.4.2.7.1.070 |  | Testing & Pre-commissioning of MV cables | 25d | 2013-01-08 | 2013-01-30 | 1.4.2.7.1.060 FF+10d, 1.4.2.7.1.130, 1.4.2.7.230, 1.4.2.7.330, 1.4.2.7.510, 1.4.2.7.1.080 FF+15d |  |  |  |  | -97.5d | 0d | SSH-Construction Manhours [1254.8 h] | 100,000 |  |
|  | 2 | **Zone 3 - A3-1 & 4** |  | 2012-10-04 | 2013-01-07 |  |  |  |  |  |  |  |  |  |  |
| 1.4.2.7.1.100 |  | Excavation of MV cable trench | 10d | 2012-10-04 | 2012-10-13 | Z3.1020 SS |  |  |  |  | -97.5d | 0d | SSH-Construction Manhours [3739.78 h]; Excavator [80 h]; Dump Truck [80 h] | 42,625 |  |
| 1.4.2.7.1.110 |  | Install MV cable A | 12.5d | 2012-10-04 | 2012-10-15 | 1.4.2.7.1.100 SS, 1.3.2.5.030 SS |  |  |  |  | -97.5d | 0d | SSH-Construction Manhours [1882.69 h]; Cable Puller [100 h] | 249,155 |  |
| 1.4.2.7.1.120 |  | Install MV cable B | 45d | 2012-10-16 | 2012-11-26 | 1.4.2.7.1.110 |  |  |  |  | -97.5d | 0d | SSH-Construction Manhours [1882.69 h]; Cable Puller [100 h] | 249,155 |  |
| 1.4.2.7.1.130 |  | Install MV cable C | 45d | 2012-11-27 | 2013-01-07 | 1.4.2.7.1.120 |  |  |  |  | -97.5d | 0d | SSH-Construction Manhours [1882.69 h]; Cable Puller [100 h] | 249,155 |  |
|  | 3 | **Zone 3 - A3-2** |  | 2011-12-15 | 2012-10-30 |  |  |  |  |  |  |  |  |  |  |
| 1.4.2.7.200 |  | Excavation of MV cable trench | 10d | 2011-12-15 A | 2011-12-25 A | 1.4.2.7.1.110 SS | 100% |  |  |  |  |  | SSH-Construction Manhours [3149.29 h]; Excavator [80 h]; Dump Truck [80 h] | 42,625 |  |
| 1.4.2.7.210 |  | Install MV cable A | 30d | 2012-02-23 A | 2012-10-13 | 1.4.2.7.1.010 SS, 1.4.2.7.200 | 69% | 9.3d | 2012-02-23 | 2012-03-22 | -22.9d | 0d | SSH-Construction Manhours [1882.69 h]; Cable Puller [100 h] | 249,155 |  |
| 1.4.2.7.220 |  | Install MV cable B | 30d | 2012-03-22 A | 2012-10-21 | 1.4.2.7.210 | 69% | 9.3d | 2012-03-22 | 2012-04-19 | -22.9d | 0d | SSH-Construction Manhours [1882.69 h]; Cable Puller [100 h] | 249,155 |  |
| 1.4.2.7.230 |  | Install MV cable C | 30d | 2012-04-19 A | 2012-10-30 | 1.4.2.7.220 | 69% | 9.3d | 2012-04-19 | 2012-05-17 | -22.9d | 74.6d | SSH-Construction Manhours [1882.69 h]; Cable Puller [100 h] | 249,155 |  |
|  | 4 | **Zone 3 - A3-3** |  | 2012-02-18 | 2012-10-30 |  |  |  |  |  |  |  |  |  |  |
| 1.4.2.7.300 |  | Excavation of MV cable trench | 25d | 2012-02-18 A | 2012-03-11 A | 1.4.2.7.1.010 SS+12.5d | 100% |  |  |  |  |  | SSH-Construction Manhours [2755.63 h]; Excavator [80 h]; Dump Truck [80 h] | 42,625 |  |
| 1.4.2.7.310 |  | Install MV cable A | 30d | 2012-03-12 A | 2012-10-13 | 1.4.2.7.1.010 SS, 1.4.2.7.300 | 69% | 9.3d | 2012-03-12 | 2012-04-08 | -22.9d | 0d | SSH-Construction Manhours [1882.69 h]; Cable Puller [100 h] | 249,155 |  |
| 1.4.2.7.320 |  | Install MV cable B | 30d | 2012-04-09 A | 2012-10-21 | 1.4.2.7.310 | 69% | 9.3d | 2012-04-09 | 2012-05-06 | -22.9d | 0d | SSH-Construction Manhours [1882.69 h]; Cable Puller [100 h] | 249,155 |  |
| 1.4.2.7.330 |  | Install MV cable C | 30d | 2012-05-07 A | 2012-10-30 | 1.4.2.7.320 | 69% | 9.3d | 2012-05-07 | 2012-06-03 | -22.9d | 74.6d | SSH-Construction Manhours [1882.69 h]; Cable Puller [100 h] | 249,155 |  |
|  | 5 | **Zone 3 - A3-4** |  | 2012-02-18 | 2012-10-22 |  |  |  |  |  |  |  |  |  |  |
| 1.4.2.7.400 |  | Excavation of MV cable trench | 25d | 2012-02-18 A | 2012-03-11 A | 1.4.2.7.1.010 SS+15d | 100% |  |  |  |  |  | SSH-Construction Manhours [2558.8 h]; Excavator [40 h]; Dump Truck [40 h] | 42,625 |  |
| 1.4.2.7.410 |  | Install MV cable A | 30d | 2012-03-12 A | 2012-10-13 | 1.4.2.7.1.010 SS, 1.4.2.7.400 | 68% | 9.6d | 2012-03-12 | 2012-04-08 | -23.8d | 0d | SSH-Construction Manhours [3137.48 h]; Cable Puller [60 h] | 249,155 |  |
| 1.4.2.7.420 |  | Install MV cable B | 30d | 2012-04-09 A | 2012-10-22 | 1.4.2.7.410 | 68% | 9.6d | 2012-04-09 | 2012-05-06 | -23.8d | 0d | SSH-Construction Manhours [3137.48 h]; Cable Puller [60 h] | 249,155 |  |

| ID | WBS | Activity | Duration | Start | Finish | Predecessors | Complete | Remaining | Planned start | Planned finish | Total float | Free float | Resources | Cost | Actual cost | QTY |
| --- | --- | --- | --- | --- | --- | --- | --- | --- | --- | --- | --- | --- | --- | --- | --- | --- |
|  | 6 | **Zone 3 - A3-5** |  | 2012-03-07 | 2012-10-31 |  |  |  |  |  |  |  |  |  |  |  |
| 1.4.2.7.500 |  | Excavation of MV cable trench | 25d | 2012-03-07 A | 2012-03-29 A | 1.4.2.7.1.010 SS+75d | 100% |  |  |  |  |  | SSH-Construction Manhours [1771.48 h]; Excavator [40 h]; Dump Truck [40 h] | 42,625 |  |  |
| 1.4.2.7.510 |  | Install MV cable A | 30d | 2012-05-07 A | 2012-10-31 | 1.4.2.7.420, 1.4.2.7.500 | 68% | 9.6d | 2012-05-07 | 2012-06-03 | -23.8d | 0d | SSH-Construction Manhours [1882.69 h]; Cable Puller [60 h] | 249,164 |  |  |
|  | 7 | **Zone 2 & 1** |  | 2011-12-03 | 2012-12-31 |  |  |  |  |  |  |  |  |  |  |  |
| 1.4.2.7.700 |  | Excavation of MV cable trench zone2 | 45d | 2011-12-03 A | 2012-10-08 | 1.4.2.7.200 SS | 90% | 4.5d | 2011-12-03 | 2012-01-12 | -64.5d | 0d | SSH-Construction Manhours [1271.53 h] | 150,000 | 75,000 |  |
| 1.4.2.7.710 |  | Install MV cable zone 2 | 45d | 2011-12-20 A | 2012-10-08 | 1.4.2.7.700 SS | 90% | 4.5d | 2011-12-20 | 2012-01-30 | -64.5d | 0d | SSH-Construction Manhours [12784.2 h] | 893,740 |  |  |
| 1.4.2.7.720 |  | Excavation of MV cable for SEC Substation | 90d | 2012-03-13 A | 2012-11-19 | 1.4.2.7.710 | 50% | 45d | 2012-03-13 | 2012-06-05 | -64.5d | 0d | SSH-Construction Manhours [1274.48 h] | 75,000 |  |  |
| 1.4.2.7.730 |  | Install MV cable zone 2 towards SEC SS | 90d | 2012-04-24 A | 2012-12-31 | 1.4.2.7.720 FF+45d | 46% | 48.84d | 2012-04-24 | 2012-07-17 | -64.5d | 33d | SSH-Construction Manhours [13442.5 h] | 937,000 |  |  |
|  | 02 | **LV Cables -(For Permanent Roads & CCTV Camera network)** |  | 2012-05-23 | 2013-05-11 |  |  |  |  |  |  |  |  |  |  |  |
| 1.4.2.7.2.010 |  | Excavation of trench for lighting power cables | 120d | 2012-05-23 A | 2013-01-23 | 1.4.2.5.3.040 FF+60d | 90% | 12d | 2012-05-23 | 2012-09-12 | -200.42d | 0d | SSH-Construction Manhours [1385.69 h]; Excavator [450 h]; Dump Truck [450 h] | 44,250 |  |  |
| 1.4.2.7.2.030 |  | Install lighting power cables (For lighting poles + CCTV Camera network) | 75d | 2012-08-01 A | 2013-02-20 | 1.4.2.7.2.010 FF+30d, 1.3.2.24.030 | 10% | 67.5d | 2012-08-01 | 2012-10-10 | -142.42d | 0d | SSH-Construction Manhours [7528.77 h]; Cable Puller [600 h] | 750,000 |  |  |
| 1.4.2.7.2.080 |  | Install lighting poles | 120d | 2012-08-15 A | 2013-04-17 | 1.3.2.20.030, 1.3.2.22.030, 1.4.2.7.2.070 FF+30d | 1% | 118.8d | 2012-08-15 | 2012-12-05 | -142.42d | 0d | SSH-Construction Manhours [5289.83 h]; Truck Crane [600 ea] | 276,528 | 989.28 |  |
| 1.4.2.7.2.050 |  | Install red tiles/cable markers for lighting cables | 40d | 2012-09-12 A | 2013-03-02 | 1.4.2.7.2.030 FF+10d | 50% | 20d | 2012-09-12 | 2012-10-20 | -142.42d | 0d | SSH-Construction Manhours [1505.75 h] | 20,550 |  |  |
| 1.4.2.7.2.091 |  | Install CCTV camera poles & CCTV Cameras | 120d | 2013-01-09 | 2013-05-01 | 1.4.2.7.2.080 FF+15d |  |  |  |  | -142.42d | 0d | SSH-Construction Manhours [1476.23 h] | 175,000 |  |  |
| 1.4.2.7.2.070 |  | Testing & commissioning of lighting cables | 40d | 2013-02-11 | 2013-03-20 | 1.4.2.7.2.050 FF+20d |  |  |  |  | -142.42d | 0d | SSH-Construction Manhours [1505.75 h] | 25,000 |  |  |
| 1.4.2.7.2.090 |  | Install lighting pole fixture | 60d | 2013-02-20 | 2013-04-17 | 1.4.2.7.2.080 FF, 1.4.2.5.2.030 SS |  |  |  |  | -127.42d | 15d | SSH-Construction Manhours [3533.11 h] | 125,000 |  | 0.1208763407 |
| 1.4.2.7.2.092 |  | Testing & Commissioning of CCTV System | 60d | 2013-03-16 | 2013-05-11 | 1.4.2.7.2.090 FF+10d, 1.4.2.7.2.091 FF+10d |  |  |  |  | -142.42d | 58d | SSH-Construction Manhours [492.08 h] | 34,200 |  |  |
|  | 03 | **LV Cables (For Patrol Roads)** |  | 2011-08-14 | 2012-11-08 |  |  |  |  |  |  |  |  |  |  |  |
| 1.4.2.7.2.110 |  | Install LV cables & Lightings in Zone1 | 18.75d | 2011-08-14 A | 2011-08-31 A | 1.4.2.5.2.010 SS, 1.3.2.23.030 SS | 100% |  |  |  |  |  | SSH-Construction Manhours [7528.77 h]; Cable Puller [150 h] | 18,186 |  |  |
| 1.4.2.7.2.150 |  | Install LV cables & Lightings in Zone3 | 31.25d | 2011-09-05 A | 2012-10-04 | 1.4.2.7.2.110 SS | 98% | 0.62d | 2011-09-05 | 2011-10-03 | 23.29d | 0d | SSH-Construction Manhours [1907.29 h]; Cable Puller [250 h] | 8,446 |  |  |
| 1.4.2.7.2.130 |  | Install LV cables & Lightings in Zone2 | 31.25d | 2011-10-19 A | 2012-10-08 | 1.4.2.7.2.110 SS | 87% | 4.06d | 2011-10-19 | 2011-11-16 | -122.06d | 8.94d | SSH-Construction Manhours [15685.4 h]; Cable Puller [250 h] | 308,235 |  |  |
| 1.4.2.7.2.170 |  | Install LV cables & Lightings in Zone4 | 25d | 2012-10-16 | 2012-11-08 | 1.4.2.5.2.040, 1.4.2.7.2.130 |  |  |  |  | -131d | 69.42d | SSH-Construction Manhours [7528.77 h]; Cable Puller [200 h] | 10,274 |  |  |
|  | 04 | **Irrigation Cables** |  | 2013-01-12 | 2013-06-15 |  |  |  |  |  |  |  |  |  |  |  |
| 1.4.2.7.3.010 |  | Excavation of trench for irrigation cables | 56.25d | 2013-01-12 | 2013-03-05 | 1.4.2.7.2.010 SS, 1.4.2.7.2.170 |  |  |  |  | -200.42d | 0d | SSH-Construction Manhours [1693.73 h]; Excavator [450 h]; Dump Truck [450 h] | 30,000 |  |  |
| 1.4.2.7.3.030 |  | Install irrigation cables | 62.5d | 2013-01-23 | 2013-03-23 | 1.4.2.7.3.010 SS+12.5d |  |  |  |  | -200.42d | 0d | SSH-Construction Manhours [4517.26 h]; Cable Puller [500 h] | 250,000 |  |  |
| 1.4.2.7.3.040 |  | Install solar powered irrigation controller | 60d | 2013-03-23 | 2013-05-18 | 1.4.2.7.3.030 |  |  |  |  | -200.42d | 0d | SSH-Construction Manhours [9034.53 h] | 50,700 |  |  |
| 1.4.2.7.3.050 |  | Testing & commissioning of irrigation system | 31.25d | 2013-05-16 | 2013-06-15 | 1.4.2.7.3.030, 1.4.2.7.3.040 FF+30d |  |  |  |  | -200.42d | 0d | SSH-Construction Manhours [3613.81 h] | 20,000 |  | 0.0059079345 |

Notes:
- 1.4.2.7.700: Expenses: (New Expense Item) 75000
- 1.4.2.7.710: Expenses: (New Expense Item) 0
- 1.4.2.7.720: Expenses: (New Expense Item) 0
- 1.4.2.7.730: Expenses: (New Expense Item) 0

| ID | WBS | Activity | Duration | Start | Finish | Predecessors | Complete | Remaining | Planned start | Planned finish | Total float | Free float | Resources | Cost | QTY |
| --- | --- | --- | --- | --- | --- | --- | --- | --- | --- | --- | --- | --- | --- | --- | --- |
|  | 05 | **Electrcial Equipments & Power Cables** |  | 2012-05-23 | 2013-05-08 |  |  |  |  |  |  |  |  |  |  |
|  | 2 | **Package Substations (For all zones)** |  | 2012-05-23 | 2013-05-08 |  |  |  |  |  |  |  |  |  |  |
| 1.4.2.7.4.030 |  | Construction of package substation foundations | 120d | 2012-05-23 A | 2013-05-01 | 1.4.2.7.2.010 SS | 3% | 117d | 2012-05-23 | 2012-09-12 | -160.42d | 0d | SSH-Construction Manhours [12046 h] | 247,000 |  |
| 1.4.2.7.4.050 |  | Install package substation zone3 | 50d | 2013-03-16 | 2013-05-01 | 1.3.2.3.020, 1.4.2.7.4.030 FF |  |  |  |  | -160.42d | 0d | SSH-Construction Manhours [602.3 h] | 137,500 |  |
| 1.4.2.7.4.040 |  | Install package substation zone2 | 30d | 2013-04-03 | 2013-05-01 | 1.3.2.3.020, 1.4.2.7.4.030 FF, 1.3.2.3.030 |  |  |  |  | -160.42d | 0d | SSH-Construction Manhours [602.3 h] | 137,500 |  |
| 1.4.2.7.4.065 |  | Install package substation zone4 | 38d | 2013-04-03 | 2013-05-08 | 1.4.2.7.4.055 FF, 1.4.2.7.4.050 FF, 1.3.2.3.020 |  |  |  |  | -139.92d | 0d | SSH-Construction Manhours [602.3 h] | 145,000 |  |
| 1.4.2.7.4.085 |  | Testing & commissioning of package substation | 31d | 2013-04-10 | 2013-05-08 | 1.4.2.7.4.065 FF |  |  |  |  | -139.92d | 0d | SSH-Construction Manhours [246.04 h] | 45,000 |  |
| 1.4.2.7.4.045 |  | Testing & commissioning of package substation | 30d | 2013-04-10 | 2013-05-08 | 1.4.2.7.4.040 FF+8d |  |  |  |  | -139.92d | 0d | SSH-Construction Manhours [250.96 h] | 110,000 |  |
| 1.4.2.7.4.055 |  | Testing & commissioning of package substation | 30d | 2013-04-10 | 2013-05-08 | 1.4.2.7.4.050 FF+8d |  |  |  |  | -139.92d | 0d | SSH-Construction Manhours [250.96 h] | 110,000 | 0.03249364 |
|  | 3 | **RMU (For all zones)** |  | 2012-05-23 | 2013-04-13 |  |  |  |  |  |  |  |  |  |  |
| 1.4.2.7.4.060 |  | Constrcution of RMU foundations | 120d | 2012-05-23 A | 2013-04-04 | 1.4.2.7.4.030 SS | 26% | 88.8d | 2012-05-23 | 2012-09-12 | -132.22d | 0d | SSH-Construction Manhours [15057.5 h] | 969,000 |  |
| 1.4.2.7.4.072 |  | Install RMU-zone3 | 60d | 2013-02-07 | 2013-04-04 | 1.4.2.7.4.070 FF, 1.3.2.4.020 |  |  |  |  | -132.22d | 0d | SSH-Construction Manhours [1317.78 h] | 1,200,000 |  |
| 1.4.2.7.4.070 |  | Install RMU-zone2 | 50d | 2013-02-17 | 2013-04-04 | 1.3.2.4.020 SS, 1.4.2.7.4.060 FF, 1.3.2.4.030 FF |  |  |  |  | -132.22d | 0d | SSH-Construction Manhours [1317.78 h] | 1,200,000 |  |
| 1.4.2.7.4.074 |  | Install RMU-zone4 | 30d | 2013-03-07 | 2013-04-04 | 1.4.2.7.4.072 FF |  |  |  |  | -104.22d | 8d | SSH-Construction Manhours [2769.41 h] | 150,000 |  |
| 1.4.2.7.4.075 |  | Testing & commissioning of road lighting RMU | 30d | 2013-03-16 | 2013-04-13 | 1.4.2.7.4.074 FF, 1.4.2.7.4.073 FF |  |  |  |  | -112.22d | 28.2d | SSH-Construction Manhours [2258.63 h] | 170,000 | 0.0502174436 |
| 1.4.2.7.4.071 |  | Testing & commissioning of RMU | 25d | 2013-03-20 | 2013-04-13 | 1.4.2.7.4.070 FF+8d |  |  |  |  | -112.22d | 0d | SSH-Construction Manhours [376.93 h] | 170,000 |  |
| 1.4.2.7.4.073 |  | Testing & commissioning of RMU | 20d | 2013-03-25 | 2013-04-13 | 1.4.2.7.4.072 FF+8d, 1.4.2.7.4.071 FF |  |  |  |  | -112.22d | 0d | SSH-Construction Manhours [376.93 h] | 170,000 |  |
|  | 4 | **Generators** |  | 2012-06-20 | 2013-04-29 |  |  |  |  |  |  |  |  |  |  |
| 1.4.2.7.4.090 |  | Construction of generator foundations | 90d | 2012-06-20 A | 2013-04-02 | 1.4.2.7.4.060 SS+30d | 5% | 85.5d | 2012-06-20 | 2012-09-12 | -80.42d | 14.58d | SSH-Construction Manhours [9034.53 h] | 102,600 |  |
| 1.4.2.7.4.101 |  | Install generator LS10 | 15d | 2013-01-26 | 2013-02-09 | 1.4.2.7.4.090 SS, 1.3.2.6.020, 1.4.2.3.6.155 |  |  |  |  | -95d | 0d | SSH-Construction Manhours [1304.99 h] | 100,000 |  |
| 1.4.2.7.4.107 |  | Install generator LS9 | 15d | 2013-03-05 | 2013-03-18 | 1.4.2.3.5.155 FF |  |  |  |  | -142.5d | 0d | SSH-Construction Manhours [1204.6 h] | 100,000 |  |
| 1.4.2.7.4.103 |  | Install generator LS11 | 15d | 2013-03-26 | 2013-04-08 | 1.4.2.3.7.155 |  |  |  |  | -161d | 0d | SSH-Construction Manhours [1204.6 h] | 100,000 |  |
| 1.4.2.7.4.105 |  | Install generator LS12 | 15d | 2013-04-16 | 2013-04-29 | 1.3.2.6.030, 1.4.2.3.8.155 |  |  |  |  | -202.5d | 0d | SSH-Construction Manhours [1204.6 h] | 100,000 |  |
|  | 5 | **Submersible Pumps** |  | 2013-01-30 | 2013-05-08 |  |  |  |  |  |  |  |  |  |  |
| 1.4.2.7.4.120 |  | Install submersible pumps - LS pumps LS10 | 10d | 2013-01-30 | 2013-02-09 | 1.3.4.4.020, 1.3.4.8.020, 1.3.4.9.020, 1.4.2.3.6.150, 1.4.2.7.4.101 FF |  |  |  |  | -95d | 0d | SSH-Construction Manhours [2948.52 h] | 50,000 |  |
| 1.4.2.7.4.126 |  | Install submersible pumps - LS pumps LS9 | 10d | 2013-03-05 | 2013-03-13 | 1.4.2.3.5.150 SS, 1.4.2.7.4.107 SS |  |  |  |  | -142.5d | 5d | SSH-Construction Manhours [3199.48 h] | 50,000 |  |
| 1.4.2.7.4.122 |  | Install submersible pumps - LS pumps LS11 | 10d | 2013-04-03 | 2013-04-13 | 1.4.2.3.7.150, 1.3.4.4.030, 1.4.2.7.4.103 FF+4d |  |  |  |  | -161d | 0d | SSH-Construction Manhours [2634.58 h] | 50,000 |  |
| 1.4.2.7.4.124 |  | Install submersible pumps - LS pumps LS12 | 10d | 2013-04-30 | 2013-05-08 | 1.4.2.3.8.150, 1.4.2.7.4.105 |  |  |  |  | -202.5d | 0d | SSH-Construction Manhours [3952.36 h] | 50,000 |  |

Notes:
- 1.4.2.7.4.065: Expenses: (New Expense Item) 0
- 1.4.2.7.4.085: Expenses: (New Expense Item) 0

| ID | WBS | Activity | Duration | Start | Finish | Predecessors | Complete | Remaining | Planned start | Planned finish | Total float | Free float | Resources | Cost | QTY |
| --- | --- | --- | --- | --- | --- | --- | --- | --- | --- | --- | --- | --- | --- | --- | --- |
|  | 06 | **Grounding Cables** |  | 2012-02-18 | 2012-12-25 |  |  |  |  |  |  |  |  |  |  |
| 1.4.2.7.5.010 |  | Excavation of trench for grounding cables | 45d | 2012-02-18 A | 2012-10-17 | 1.4.3.2.1.110 SS+5d | 69% | 13.95d | 2012-02-18 | 2012-03-29 | -80.55d | 0d | SSH-Construction Manhours [4025.19 h] | 25,000 |  |
| 1.4.2.7.5.030 |  | Install grounding cables | 35d | 2012-04-14 A | 2012-11-05 | 1.3.2.15.030, 1.4.2.7.5.010 FF+20d | 64% | 12.75d | 2012-04-14 | 2012-05-15 | -80.55d | 0d | SSH-Construction Manhours [8131.08 h] | 60,340 |  |
| 1.4.2.7.5.020 |  | backfilling/compaction of grounding cable trench | 20d | 2012-06-18 A | 2012-12-25 | 1.4.2.7.5.040 SS+30d | 7% | 18.6d | 2012-06-18 | 2012-07-05 | -80.55d | 0d | SSH-Construction Manhours [2258.63 h] | 20,000 |  |
| 1.4.2.7.5.040 |  | Testing & commissioning of grounding cables | 15d | 2012-11-10 | 2012-11-24 | 1.4.2.7.5.030 FF+20d |  |  |  |  | -80.55d | 0d | SSH-Construction Manhours [1254.8 h] | 15,000 | 0.0044309509 |
|  | 7 | **Communication Works & Duct Banks** |  | 2012-02-20 | 2013-01-07 |  |  |  |  |  |  |  |  |  |  |
|  | 1 | **Communication works & Ductbanks** |  | 2012-02-20 | 2013-01-07 |  |  |  |  |  |  |  |  |  |  |
| 1.4.2.8.1.040 |  | Construction of comm concrete ductbanks | 90d | 2012-02-20 A | 2012-11-07 | 1.4.2.7.2.150 SS | 59% | 36.71d | 2012-02-20 | 2012-05-14 | 23.29d | 13.29d | SSH-Construction Manhours [13428.9 h] | 1,486,811 |  |
| 1.4.2.8.1.010 |  | Excavation of telecomm ductbanks & trench Zone3 -A3-1 | 35d | 2012-02-21 A | 2012-10-04 | 1.4.2.8.1.012 FF+20d | 100% | 0d | 2012-02-21 | 2012-03-25 | -10.5d | 0d | SSH-Construction Manhours [1990.66 h]; Excavator [150 h]; Dump Truck [150 h] | 32,900 |  |
| 1.4.2.8.1.012 |  | Excavation of telecomm ductbanks & trench Zone3 -A3-3 | 35d | 2012-02-25 A | 2012-03-28 A | 1.4.2.7.200 SS | 100% |  |  |  |  |  | SSH-Construction Manhours [3791.88 h]; Excavator [200 h]; Dump Truck [200 h] | 32,900 |  |
| 1.4.2.8.1.011 |  | Excavation of telecomm ductbanks & trench Zone3 -A3-2 | 35d | 2012-03-06 A | 2012-04-08 A | 1.4.2.8.1.010 FF+15d | 100% |  |  |  |  |  | SSH-Construction Manhours [1895.94 h]; Dump Truck [200 h]; Excavator [200 h] | 32,900 |  |
| 1.4.2.8.1.013 |  | Excavation of telecomm ductbanks & trench Zone3 -A3-4 | 35d | 2012-03-20 A | 2012-04-22 A | 1.4.2.8.1.011 FF+15d | 100% |  |  |  |  |  | SSH-Construction Manhours [1895.94 h]; Dump Truck [100 h]; Excavator [100 h] | 32,900 |  |
| 1.4.2.8.1.014 |  | Excavation of telecomm ductbanks & trench Zone3 -A3-5 | 35d | 2012-04-03 A | 2012-05-06 A | 1.4.2.8.1.013 FF+15d | 100% |  |  |  |  |  | SSH-Construction Manhours [1895.94 h]; Excavator [100 h]; Dump Truck [100 h] | 32,900 |  |
| 1.4.2.8.1.021 |  | Install comm conduits & fittings-Zone 3 - A3-2 | 27.5d | 2012-04-08 A | 2012-05-03 A | 1.4.2.8.1.011, 1.3.3.5.030 | 100% |  |  |  |  |  | SSH-Construction Manhours [4170.76 h] | 24,286 |  |
| 1.4.2.8.1.015 |  | Excavation of telecomm ductbanks & trench Zone2 | 35d | 2012-04-17 A | 2012-10-20 | 1.4.2.8.1.014 FF+15d | 50% | 17.5d | 2012-04-17 | 2012-05-20 | 17d | 0d | SSH-Construction Manhours [1895.94 h]; Dump Truck [100 h]; Excavator [100 h] | 32,900 |  |
| 1.4.2.8.1.031 |  | Install comm manholes-Zone 3 - A3-2 (5) | 25d | 2012-04-19 A | 2012-10-17 | 1.4.2.8.1.021 FF+10d | 49% | 12.75d | 2012-04-19 | 2012-05-13 | -6.75d | 3.75d | SSH-Construction Manhours [2849.26 h] | 50,700 |  |
| 1.4.2.8.1.023 |  | Install comm conduits & fittings-Zone 3 - A3-4 | 25d | 2012-04-22 A | 2012-05-15 A | 1.4.2.8.1.013 | 100% |  |  |  |  |  | SSH-Construction Manhours [2274.82 h] | 24,286 |  |
| 1.4.2.8.1.022 |  | Install comm conduits & fittings-Zone 3 - A3-3 | 27.5d | 2012-05-03 A | 2012-05-29 A | 1.4.2.8.1.021 | 100% |  |  |  |  |  | SSH-Construction Manhours [4170.76 h] | 24,286 |  |
| 1.4.2.8.1.024 |  | Install comm conduits & fittings-Zone 3 - A3-5 | 25d | 2012-05-06 A | 2012-05-29 A | 1.4.2.8.1.014 | 100% |  |  |  |  |  | SSH-Construction Manhours [2274.82 h] | 24,286 |  |
| 1.4.2.8.1.032 |  | Install comm manholes-Zone 3 - A3-3 (7) | 25d | 2012-05-15 A | 2012-10-17 | 1.4.2.8.1.022 FF+10d | 68% | 8d | 2012-05-15 | 2012-06-07 | 20.75d | 31.25d | SSH-Construction Manhours [3981.32 h] | 70,980 |  |
| 1.4.2.8.1.025 |  | Install comm conduits & fittings-Zone 2 | 25d | 2012-05-20 A | 2012-10-31 | 1.4.2.8.1.015 | 50% | 12.5d | 2012-05-20 | 2012-06-12 | 17d | 0d | SSH-Construction Manhours [1819.55 h] | 24,286 |  |
| 1.4.2.8.1.035 |  | Install comm manholes-Zone 2 (4) | 25d | 2012-05-24 A | 2012-11-05 | 1.4.2.8.1.025 FF+5d | 12% | 22d | 2012-05-24 | 2012-06-17 | 17d | 0d | SSH-Construction Manhours [2276.35 h] | 40,560 |  |
| 1.4.2.8.1.020 |  | Install comm conduits & fittings-Zone 3 - A3-1 | 22.5d | 2012-05-29 A | 2012-06-19 A | 1.4.2.8.1.010, 1.3.3.11.030, 1.3.3.12.030 | 100% |  |  |  |  |  | SSH-Construction Manhours [4265.48 h] | 24,286 |  |
| 1.4.2.8.1.030 |  | Install comm manholes-Zone 3 - A3-1(5) | 25d | 2012-06-10 A | 2012-10-16 | 1.4.2.8.1.020 SS+12.5d, 1.3.3.13.030 | 49% | 12.75d | 2012-06-10 | 2012-07-03 | -10.5d | 0d | SSH-Construction Manhours [2844.67 h] | 50,700 |  |
| 1.4.2.8.1.060 |  | backfilling/compaction of comm trench | 60d | 2012-07-07 A | 2012-11-28 | 1.4.2.8.1.050 FF | 22% | 46.8d | 2012-07-07 | 2012-08-30 | 32d | 42.5d | SSH-Construction Manhours [2847.73 h] | 317,260 |  |
| 1.4.2.8.1.110 |  | Complete Teleecomm siteworks | 2d | 2012-09-20 A | 2012-09-23 A | 1.4.2.8.1.082, 1.4.2.8.1.100, 1.4.2.8.1.088, 1.4.2.8.1.080, 1.4.2.8.1.060 FF, 1.4.2.8.1.055, 1.4.2.8.1.086, 1.4.2.8.1.130, 1.4.2.8.1.150 | 100% |  |  |  |  |  | SSH-Construction Manhours |  |  |
| 1.4.2.8.1.016 |  | Excavation of telecomm ductbanks & trench Zone4 | 35d | 2012-10-04 | 2012-11-05 | 1.4.2.8.1.015 FF+15d |  |  |  |  | 14.5d | 0d | SSH-Construction Manhours [1138.17 h]; Excavator [60 h]; Dump Truck [60 h] | 32,900 |  |
| 1.4.2.8.1.033 |  | Install comm manholes-Zone 3 - A3-4 (5) | 25d | 2012-10-04 | 2012-10-27 | 1.4.2.8.1.023 FF+15d |  |  |  |  | 42d | 52.5d | SSH-Construction Manhours [2849.26 h] | 50,700 |  |
| 1.4.2.8.1.034 |  | Install comm manholes-Zone 3 - A3-5 (2) | 25d | 2012-10-04 | 2012-10-27 | 1.4.2.8.1.024 FF+5d |  |  |  |  | 54.5d | 65d | SSH-Construction Manhours [1138.17 h] | 20,280 |  |
| 1.4.2.8.1.050 |  | Install Comm Code Blue system & accs | 60d | 2012-10-04 | 2012-11-28 | 1.4.2.8.1.040 FF+10d, 1.3.3.16.020, 1.3.3.16.030, 1.3.3.17.030 |  |  |  |  | 10d | 0d | SSH-Construction Manhours [3636.05 h] | 156,000 |  |
| 1.4.2.8.1.082 |  | Install FOC [Fiber Optic Cable] Zone3 - A3-1 | 18.75d | 2012-10-04 | 2012-10-21 | 1.4.2.8.1.030 SS, 1.3.3.1.030 |  |  |  |  | -10.5d | 0d | SSH-Construction Manhours [6065.17 h]; Cable Puller [150 h] | 94,285 |  |
| 1.4.2.8.1.090 |  | Install comm grounding system | 37.5d | 2012-10-04 | 2012-11-07 | 1.3.3.10.030 |  |  |  |  | 55d | 44.5d | SSH-Construction Manhours [3413 h]; Cable Puller [300 h] | 75,000 |  |
| 1.4.2.8.1.051 |  | Install CCTV System & accs | 60d | 2012-10-14 | 2012-12-08 | 1.4.2.8.1.050 FF+10d, 1.3.3.14.020 |  |  |  |  | 10d | 0d | SSH-Construction Manhours [3636.05 h] | 156,000 |  |
| 1.4.2.8.1.055 |  | Install comm copper cables closure | 37.5d | 2012-10-18 | 2012-11-21 | 1.4.2.8.1.050 SS+15d, 1.3.3.9.030, 1.3.3.3.030 |  |  |  |  | 29.5d | 19.5d | SSH-Construction Manhours [1818.02 h] | 73,000 |  |
| 1.4.2.8.1.100 |  | Install red tiles /cable markers | 60d | 2012-10-18 | 2012-12-12 | 1.4.2.8.1.050 SS+15d |  |  |  |  | 17d | 27.5d | SSH-Construction Manhours [3791.88 h] | 81,722 |  |
| 1.4.2.8.1.083 |  | Install FOC [Fiber Optic Cable] Zone3 - A3-2 | 27.5d | 2012-10-22 | 2012-11-15 | 1.4.2.8.1.031, 1.4.2.8.1.082 |  |  |  |  | -10.5d | 0d | SSH-Construction Manhours [4170.76 h]; Cable Puller [220 h] | 94,285 |  |
| 1.4.2.8.1.070 |  | Install comm subduct materials | 50d | 2012-10-28 | 2012-12-12 | 1.4.2.8.1.050 FF+15d |  |  |  |  | 12d | 0d | SSH-Construction Manhours [5860.45 h]; Cable Puller [400 h] | 240,000 |  |
| 1.4.2.8.1.026 |  | Install comm conduits & fittings-Zone 4 | 25d | 2012-11-06 | 2012-11-28 | 1.4.2.8.1.016 |  |  |  |  | 14.5d | 0d | SSH-Construction Manhours [1819.55 h] | 24,286 |  |
| 1.4.2.8.1.080 |  | Install comm copper cables | 45d | 2012-11-06 | 2012-12-17 | 1.4.2.8.1.070 SS+10d, 1.3.3.4.030 |  |  |  |  | 12d | 22.5d | SSH-Construction Manhours [3781.18 h] | 609,710 |  |
| 1.4.2.8.1.087 |  | Install FOC [Fiber Optic Cable] Zone2 | 27.5d | 2012-11-06 | 2012-12-01 | 1.4.2.8.1.035, 1.4.2.8.1.082 |  |  |  |  | 17d | 2.5d | SSH-Construction Manhours [3338.14 h]; Cable Puller [220 h] | 94,285 |  |
| 1.4.2.8.1.036 |  | Install comm manholes-Zone 4 (2) | 25d | 2012-11-11 | 2012-12-03 | 1.4.2.8.1.026 FF+5d |  |  |  |  | 14.5d | 0d | SSH-Construction Manhours [1138.17 h] | 20,280 |  |
| 1.4.2.8.1.084 |  | Install FOC [Fiber Optic Cable] Zone3 - A3-3 | 31.25d | 2012-11-17 | 2012-12-15 | 1.4.2.8.1.032, 1.4.2.8.1.083 |  |  |  |  | -10.5d | 0d | SSH-Construction Manhours [4740.61 h]; Cable Puller [250 h] | 94,285 |  |
| 1.4.2.8.1.130 |  | Testing & Commissioning of Code Blue System | 20d | 2012-11-29 | 2012-12-17 | 1.4.2.8.1.050 |  |  |  |  | 12d | 2d | SSH-Construction Manhours [1990.66 h] | 20,000 |  |
| 1.4.2.8.1.088 |  | Install FOC [Fiber Optic Cable] Zone4 | 12.5d | 2012-12-04 | 2012-12-15 | 1.4.2.8.1.036, 1.4.2.8.1.087 |  |  |  |  | 14.5d | 25d | SSH-Construction Manhours [1895.94 h]; Cable Puller [100 h] | 94,285 |  |
| 1.4.2.8.1.150 |  | Testing & Commissioning of CCTV System | 12d | 2012-12-09 | 2012-12-19 | 1.4.2.8.1.055 FF+10d, 1.4.2.8.1.051 |  |  |  |  | 10d | 0d | SSH-Construction Manhours [1990.66 h] | 20,000 |  |
| 1.4.2.8.1.085 |  | Install FOC [Fiber Optic Cable] Zone3 - A3-4 | 12.5d | 2012-12-16 | 2012-12-26 | 1.4.2.8.1.033, 1.4.2.8.1.084 |  |  |  |  | -10.5d | 0d | SSH-Construction Manhours [1138.17 h]; Cable Puller [100 h] | 94,285 |  |
| 1.4.2.8.1.086 |  | Install FOC [Fiber Optic Cable] Zone3 - A3-5 | 12.5d | 2012-12-27 | 2013-01-07 | 1.4.2.8.1.034, 1.4.2.8.1.085 |  |  |  |  | -10.5d | 0d | SSH-Construction Manhours [1138.17 h]; Cable Puller [100 h] | 94,285 |  |

| ID | WBS | Activity | Duration | Start | Finish | Predecessors | Complete | Remaining | Planned start | Planned finish | Total float | Free float | Resources | Cost | QTY |
| --- | --- | --- | --- | --- | --- | --- | --- | --- | --- | --- | --- | --- | --- | --- | --- |
|  | 3 | **BUILDING WORKS** |  | 2011-10-02 | 2013-05-07 |  |  |  |  |  |  |  |  |  |  |
|  | 1 | **Substations** |  | 2011-10-08 | 2013-01-23 |  |  |  |  |  |  |  |  |  |  |
|  | 1 | **Substation # 4** |  | 2011-10-10 | 2013-01-23 |  |  |  |  |  |  |  |  |  |  |
|  | 1 | **Civil Works** |  | 2011-10-10 | 2012-01-08 |  |  |  |  |  |  |  |  |  |  |
| 1.4.3.1.1.010 |  | Excavation leveling & cpmpactionfor SS4 fdns | 30d | 2011-10-10 A | 2011-11-03 A | 1.2.6.200, 1.4.1.3.4.010 SS | 100% |  | 2011-08-08 | 2011-09-04 |  |  | SSH-Construction Manhours [281.8 h]; Excavator [240 h]; Dump Truck [240 h] | 8,200 |  |
| 1.4.3.1.1.060 |  | backfill/compaction | 25d | 2011-12-17 A | 2012-01-08 A | 1.4.3.1.1.020 SS | 100% |  |  |  |  |  | SSH-Construction Manhours [234.44 h]; Dump Truck [200 h]; Compactor [200 h] | 94,010 | 0.0277702463 |
|  | 2 | **Structural Works** |  | 2011-10-31 | 2012-10-30 |  |  |  |  |  |  |  |  |  |  |
| 1.4.3.1.1.050 |  | Install RSB/FW/concrete for SS4 columns | 50d | 2011-10-31 A | 2011-12-15 A | 1.4.3.1.1.060 SS, 1.4.3.1.1.030 | 100% |  |  |  |  |  | SSH-Construction Manhours [2935.51 h] | 27,040 |  |
| 1.4.3.1.1.020 |  | Install RSB/FW/concrete fdns | 50d | 2011-11-04 A | 2011-11-26 A | 1.3.1.1.030 SS | 100% |  | 2011-08-22 | 2011-10-06 |  |  | SSH-Construction Manhours [2935.51 h] | 49,920 |  |
| 1.4.3.1.1.030 |  | Install RSB/FW/concrete for ground beams | 50d | 2011-11-30 A | 2011-12-20 A | 1.4.3.1.1.020 SS | 100% |  | 2011-09-14 | 2011-10-30 |  |  | SSH-Construction Manhours [2935.51 h] | 21,840 |  |
| 1.4.3.1.1.070 |  | Install RSB/FW/concrete for roof beams | 50d | 2012-02-18 A | 2012-04-03 A | 1.4.3.1.1.050 FF+25d | 100% |  |  |  |  |  | SSH-Construction Manhours [2935.51 h] | 66,560 |  |
| 1.4.3.1.1.080 |  | Install RSB/FW/concrete for SS4 roof slab | 40d | 2012-03-07 A | 2012-10-30 | 1.4.3.1.1.070 SS+20d | 30% | 28d | 2012-03-07 | 2012-04-12 | -68.75d | 0d | SSH-Construction Manhours [2935.51 h] | 569,500 |  |
| 1.4.3.1.1.090 |  | Install CMU blocks | 30d | 2012-04-14 A | 2012-05-10 A | 1.4.3.1.1.080 SS+20d, 1.3.1.5.030, 1.2.5.030 | 100% |  |  |  |  |  | SSH-Construction Manhours [1127.2 h] | 78,660 | 0.0232359065 |
| 1.4.3.1.1.040 |  | Install RSB/FW/concrete for equipment fdns | 50d | 2012-05-12 A | 2012-10-20 | 1.3.1.2.030, 1.4.3.1.1.090 | 65% | 17.5d | 2012-05-12 | 2012-06-26 | -32.5d | 35d | SSH-Construction Manhours [2029.31 h] | 41,600 |  |
|  | 3 | **Architectural Works** |  | 2012-04-28 | 2012-12-10 |  |  |  |  |  |  |  |  |  |  |
| 1.4.3.1.1.100 |  | Install Plastering work | 25d | 2012-04-28 A | 2012-10-04 | 1.4.3.1.1.090 SS+15d | 95% | 1.25d | 2012-04-28 | 2012-05-20 | -68.75d | 0d | SSH-Construction Manhours [751.27 h] | 45,000 |  |
| 1.4.3.1.1.110 |  | Install floor finishing works - [Tiling] | 30d | 2012-10-04 | 2012-10-31 | 1.4.3.1.1.100 SS+12.5d, 1.3.1.4.030 |  |  |  |  | -68.75d | 0d | SSH-Construction Manhours [563.6 h] | 75,500 |  |
| 1.4.3.1.1.130 |  | Install roof water proofing system | 25d | 2012-10-04 | 2012-10-27 | 1.4.3.1.1.100 SS |  |  |  |  | -38.75d | 30d | SSH-Construction Manhours [219.83 h] | 110,600 |  |
| 1.4.3.1.1.120 |  | Install wall finishing works | 30d | 2012-10-18 | 2012-11-14 | 1.4.3.1.1.110 SS+15d, 1.3.1.4.030, 1.3.1.19.020 |  |  |  |  | -68.75d | 0d | SSH-Construction Manhours [563.6 h] | 88,000 |  |
| 1.4.3.1.1.125 |  | Install Ceiling finishing work | 30d | 2012-10-30 | 2012-11-26 | 1.4.3.1.1.120 SS+12.5d, 1.3.1.20.020 |  |  |  |  | -36.25d | 32.5d | SSH-Construction Manhours [422.7 h] | 45,000 | 0.0044309509 |
| 1.4.3.1.1.140 |  | Install painting works | 15d | 2012-11-15 | 2012-11-28 | 1.4.3.1.1.130 SS+15d, 1.4.3.1.1.120 |  |  |  |  | -68.75d | 0d | SSH-Construction Manhours [281.8 h] | 50,000 |  |
| 1.4.3.1.1.150 |  | Install doors & windows with frames | 12.5d | 2012-11-29 | 2012-12-10 | 1.4.3.1.1.140, 1.4.3.1.1.125 SS, 1.3.1.7.030, 1.3.1.8.030, 1.3.1.18.020, 1.3.1.21.020 |  |  |  |  | -68.75d | 0d | SSH-Construction Manhours [140.9 h] | 72,400 |  |
|  | 4 | **Plumbing Works** |  | 2012-05-19 | 2012-10-30 |  |  |  |  |  |  |  |  |  |  |
| 1.4.3.1.1.210 |  | Install plumbing works | 31.25d | 2012-05-19 A | 2012-10-30 | 1.4.3.1.1.100 SS, 1.3.4.7.030, M1.09 | 10% | 28.12d | 2012-05-19 | 2012-06-17 | -36.12d | 0d | SSH-Construction Manhours [1409 h] | 25,500 |  |
| 1.4.3.1.1.220 |  | Install eye wash & shower | 18d | 2012-10-04 | 2012-10-21 | 1.4.3.1.1.210 SS+12.5d |  |  |  |  | -1d | 32d | SSH-Construction Manhours [211.64 h] | 6,750 | 0.0019939279 |

| ID | WBS | Activity | Duration | Start | Finish | Predecessors | Complete | Remaining | Planned start | Planned finish | Total float | Free float | Resources | Cost | QTY |
| --- | --- | --- | --- | --- | --- | --- | --- | --- | --- | --- | --- | --- | --- | --- | --- |
|  | 5 | **Mechanical / HVAC Works** |  | 2012-10-04 | 2012-12-02 |  |  |  |  |  |  |  |  |  |  |
| 1.4.3.1.1.330 |  | Install ducting works & DDC | 45d | 2012-10-04 | 2012-11-14 | 1.4.3.1.1.210 SS |  |  |  |  | -33d | 0d | SSH-Construction Manhours [1584.98 h] | 35,000 |  |
| 1.4.3.1.1.340 |  | Install air inlet & outlet accs | 30d | 2012-10-23 | 2012-11-19 | 1.4.3.1.1.330 SS+20d |  |  |  |  | -33d | 0d | SSH-Construction Manhours [264.26 h] | 25,000 |  |
| 1.4.3.1.1.310 |  | Install ACCU [Air cooled condencing unit] equipments | 15d | 2012-10-30 | 2012-11-13 | 1.4.3.1.1.210 |  |  |  |  | -36.12d | 0d | SSH-Construction Manhours [351.96 h] | 350,000 |  |
| 1.4.3.1.1.350 |  | Install fire & volume dampers | 20d | 2012-11-01 | 2012-11-19 | 1.4.3.1.1.340 SS+10d, 1.3.2.25.030 |  |  |  |  | -33d | 0d | SSH-Construction Manhours [187.67 h] | 25,000 |  |
| 1.4.3.1.1.320 |  | Install AHU [Air Handling Unit] equipments with DDC panel | 15d | 2012-11-08 | 2012-11-22 | 1.4.3.1.1.310 SS+10d |  |  |  |  | -36.12d | 0d | SSH-Construction Manhours [351.96 h] | 340,000 |  |
| 1.4.3.1.1.360 |  | Install sandtrap louvers | 20d | 2012-11-11 | 2012-11-28 | 1.4.3.1.1.350 SS+10d |  |  |  |  | -33d | 0d | SSH-Construction Manhours [187.67 h] | 5,600 |  |
| 1.4.3.1.1.390 |  | Testing & balancing of HVAC system | 15d | 2012-11-18 | 2012-12-02 | 1.4.3.1.1.320 SS+10d, 1.4.3.1.1.380 FF |  |  |  |  | -36.12d | 53.88d | SSH-Construction Manhours [211.64 h] | 7,500 | 0.0022154755 |
| 1.4.3.1.1.370 |  | Install exhaust fan | 10d | 2012-11-20 | 2012-11-28 | 1.4.3.1.1.360 SS+10d |  |  |  |  | -33d | 0d | SSH-Construction Manhours [140.9 h] | 7,595 |  |
| 1.4.3.1.1.380 |  | Install fire extinguishers | 10d | 2012-11-20 | 2012-11-28 | 1.4.3.1.1.370 SS, 1.4.3.1.1.220 |  |  |  |  | -33d | 3.12d | SSH-Construction Manhours [140.9 h] | 15,500 |  |
|  | 6 | **Electrical Works** |  | 2012-05-12 | 2013-01-23 |  |  |  |  |  |  |  |  |  |  |
| 1.4.3.1.1.410 |  | Install electrical conduits & fittings | 45d | 2012-05-12 A | 2012-11-06 | 1.4.3.1.1.090, 1.3.2.16.030 | 20% | 36d | 2012-05-12 | 2012-06-21 | -67.5d | 0d | SSH-Construction Manhours [739.58 h] | 25,000 |  |
| 1.4.3.1.1.500 |  | Install grounding system | 25d | 2012-06-09 A | 2012-07-01 A | 1.4.3.1.1.480 SS+25d | 100% |  |  |  |  |  | SSH-Construction Manhours [234.44 h] | 45,000 |  |
| 1.4.3.1.1.550 |  | Install batterybank & battery charger | 7.5d | 2012-08-01 A | 2012-12-22 | 1.4.3.1.1.540 SS+3.75d, 1.3.2.13.030 | 100% | 0d | 2012-08-01 | 2012-08-07 | -68.75d | 21.25d | SSH-Construction Manhours [140.9 h] | 100,000 |  |
| 1.4.3.1.1.480 |  | Install cables trays | 60d | 2012-10-04 | 2012-11-28 | 1.4.3.1.1.410 SS+5d |  |  |  |  | -67.5d | 0d | SSH-Construction Manhours [1125.45 h] | 35,000 |  |
| 1.4.3.1.1.490 |  | Install FAS-Fire Alarm system & FACP | 18.75d | 2012-10-04 | 2012-10-21 | 1.3.2.17.030 |  |  |  |  | 3.75d | 72.5d | SSH-Construction Manhours [440.24 h] | 65,000 |  |
| 1.4.3.1.1.420 |  | Install cables & wires | 37.5d | 2012-10-18 | 2012-11-21 | 1.4.3.1.1.480 SS+15d |  |  |  |  | -67.5d | 0d | SSH-Construction Manhours [563.6 h] | 15,000 |  |
| 1.4.3.1.1.430 |  | Install lighting fixtures | 12.5d | 2012-11-11 | 2012-11-21 | 1.4.3.1.1.420 SS+25d |  |  |  |  | -67.5d | 0d | SSH-Construction Manhours [422.7 h] | 72,000 |  |
| 1.4.3.1.1.440 |  | Install Switchgear | 7.5d | 2012-11-22 | 2012-11-28 | 1.4.3.1.1.430, 1.4.3.1.1.500, 1.3.2.1.030, 1.4.3.1.1.040 |  |  |  |  | -67.5d | 0d | SSH-Construction Manhours [281.8 h] | 52,000 |  |
| 1.4.3.1.1.450 |  | Install Package substation | 7.5d | 2012-12-03 | 2012-12-09 | 1.4.3.1.1.440 FS+3.75d |  |  |  |  | -67.5d | 0d | SSH-Construction Manhours [281.8 h] | 20,750 |  |
| 1.4.3.1.1.460 |  | Install RMU | 12.5d | 2012-12-10 | 2012-12-20 | 1.4.3.1.1.450 |  |  |  |  | -67.5d | 1.25d | SSH-Construction Manhours [329.16 h] | 26,000 |  |
| 1.4.3.1.1.470 |  | Install Transformer | 12.5d | 2012-12-11 | 2012-12-22 | 1.4.3.1.1.460 SS, 1.3.2.7.030, 1.4.3.1.1.150 |  |  |  |  | -68.75d | 0d | SSH-Construction Manhours [187.67 h] | 32,500 |  |
| 1.4.3.1.1.510 |  | Install switchboard | 7.5d | 2012-12-11 | 2012-12-17 | 1.4.3.1.1.470 SS, 1.4.3.1.1.490 SS, 1.3.2.10.030 |  |  |  |  | -68.75d | 0d | SSH-Construction Manhours [281.8 h] | 210,000 |  |
| 1.4.3.1.1.520 |  | Install main distribution panel board | 7.5d | 2012-12-13 | 2012-12-19 | 1.4.3.1.1.510 SS+2.5d, 1.3.2.2.030, 1.3.2.11.030 |  |  |  |  | -68.75d | 0d | SSH-Construction Manhours [281.8 h] | 60,000 |  |
| 1.4.3.1.1.530 |  | Install circuit breaker | 7.5d | 2012-12-16 | 2012-12-22 | 1.4.3.1.1.520 SS+2.5d, 1.3.2.8.030 |  |  |  |  | -68.75d | 0d | SSH-Construction Manhours [140.9 h] | 39,000 |  |
| 1.4.3.1.1.540 |  | Install annunciator panel | 7.5d | 2012-12-18 | 2012-12-24 | 1.4.3.1.1.530 SS+2.5d, 1.3.2.12.030 |  |  |  |  | -68.75d | 0d | SSH-Construction Manhours [140.9 h] | 20,000 |  |
| 1.4.3.1.1.560 |  | Testing /commissioning of electrical system | 12d | 2013-01-10 | 2013-01-21 | 1.4.3.1.1.550, 1.2.8.020, 1.4.3.1.1.510 |  |  |  |  | -90d | 0d | SSH-Construction Manhours [281.8 h] | 150,000 |  |
| 1.4.3.1.1.570 |  | Energize Substation 4 | 3d | 2013-01-21 | 2013-01-23 | 1.4.3.1.1.560, 1.4.3.1.1.390, 1.4.3.1.1.640, 1.4.3.1.1.510 |  |  |  |  | -90d | 7.5d | SSH-Construction Manhours [43.85 h] | 20,000 | 0.0059079345 |

| ID | WBS | Activity | Duration | Start | Finish | Predecessors | Complete | Remaining | Planned start | Planned finish | Total float | Free float | Resources | Cost | QTY |
| --- | --- | --- | --- | --- | --- | --- | --- | --- | --- | --- | --- | --- | --- | --- | --- |
|  | 7 | **Communication Works** |  | 2012-05-21 | 2013-01-13 |  |  |  |  |  |  |  |  |  |  |
| 1.4.3.1.1.610 |  | Install comm conduits & fittings | 45d | 2012-05-21 A | 2012-10-24 | 1.4.3.1.1.410 SS+10d | 50% | 22.5d | 2012-05-21 | 2012-07-01 | -3d | 0d | SSH-Construction Manhours [845.4 h] | 17,000 |  |
| 1.4.3.1.1.620 |  | Install comm cabinet & accs & Data interworks | 15d | 2012-10-04 | 2012-10-17 | 1.4.3.1.1.610 SS+30d |  |  |  |  | -3d | 77.55d | SSH-Construction Manhours [140.9 h] | 75,500 |  |
| 1.4.3.1.1.630 |  | Install comm equipments & accs | 15d | 2012-12-25 | 2013-01-08 | 1.4.3.1.1.620 SS+10d, 1.3.3.2.030, 1.4.2.7.5.020 |  |  |  |  | -80.55d | 0d | SSH-Construction Manhours [140.9 h] | 185,000 |  |
| 1.4.3.1.1.640 |  | Install comm outlet & accs | 10d | 2013-01-03 | 2013-01-13 | 1.4.3.1.1.630 SS+10d |  |  |  |  | -80.55d | 9.45d | SSH-Construction Manhours [94.13 h] | 3,000 | 0.0008861902 |
|  | 8 | **Pavement / Parking / Signs / Markings** |  | 2012-10-04 | 2012-12-12 |  |  |  |  |  |  |  |  |  |  |
| 1.4.3.1.1.710 |  | Install gravel pavement | 40d | 2012-10-04 | 2012-11-10 | 1.4.3.1.1.100 SS |  |  |  |  | 17d | 0d | SSH-Construction Manhours [844.23 h] | 5,467 |  |
| 1.4.3.1.1.720 |  | Install 150mm thick concrete pavement | 30d | 2012-10-14 | 2012-11-10 | 1.4.3.1.1.710 SS+10d |  |  |  |  | 17d | 0d | SSH-Construction Manhours [705.08 h] | 36,110 |  |
| 1.4.3.1.1.730 |  | Install 500mm thick general fill | 30d | 2012-10-23 | 2012-11-19 | 1.4.3.1.1.720 SS+10d |  |  |  |  | 17d | 0d | SSH-Construction Manhours [705.08 h] | 17,400 |  |
| 1.4.3.1.1.740 |  | Install 200mm thk aggregate base coarse | 30d | 2012-11-01 | 2012-11-28 | 1.4.3.1.1.730 SS+10d |  |  |  |  | 17d | 0d | SSH-Construction Manhours [705.08 h] | 9,048 |  |
| 1.4.3.1.1.750 |  | Install 120mm thk asphalt cncrt pavement | 20d | 2012-11-11 | 2012-11-28 | 1.4.3.1.1.740 SS+10d |  |  |  |  | 17d | 0d | SSH-Construction Manhours [469.47 h] | 27,840 |  |
| 1.4.3.1.1.760 |  | Install shaded parking space | 18d | 2012-11-20 | 2012-12-06 | 1.4.3.1.1.750 SS+10d |  |  |  |  | 17d | 0d | SSH-Construction Manhours [169.55 h] | 56,700 |  |
| 1.4.3.1.1.770 |  | Install road / park markings | 10d | 2012-11-29 | 2012-12-08 | 1.4.3.1.1.760 SS+10d |  |  |  |  | 17d | 0d | SSH-Construction Manhours [94.13 h] | 37,500 |  |
| 1.4.3.1.1.780 |  | Install road / parking signs | 10d | 2012-12-04 | 2012-12-12 | 1.4.3.1.1.770 SS+5d |  |  |  |  | 17d | 217.42d | SSH-Construction Manhours [94.13 h] | 7,560 | 0.0022331993 |
|  | 9 | **Perimeter Fence System** |  | 2012-11-11 | 2012-12-10 |  |  |  |  |  |  |  |  |  |  |
| 1.4.3.1.1.810 |  | Install perimeter fence type SSD-1 | 30d | 2012-11-11 | 2012-12-08 | 1.4.3.1.1.710 |  |  |  |  | 20d | 0d | SSH-Construction Manhours [422.7 h] | 82,350 |  |
| 1.4.3.1.1.820 |  | Install perimeter gate SSD-1 10.5m wide 2 leaf | 10d | 2012-12-01 | 2012-12-10 | 1.4.3.1.1.810 SS+22d |  |  |  |  | 20d | 220.42d | SSH-Construction Manhours [187.67 h] | 15,000 | 0.0044309509 |
|  | 2 | **Substation # 5** |  | 2011-10-08 | 2013-01-06 |  |  |  |  |  |  |  |  |  |  |
|  | 1 | **Civil Works** |  | 2011-10-10 | 2012-01-08 |  |  |  |  |  |  |  |  |  |  |
| 1.4.3.1.2.010 |  | Excavation leveling & compactionfor SS5 fdns | 30d | 2011-10-10 A | 2011-11-13 A | 1.4.3.1.1.010 SS, 1.2.6.200 | 100% |  | 2011-08-08 | 2011-09-04 |  |  | SSH-Construction Manhours [281.8 h]; Excavator [240 h]; Dump Truck [240 h] | 8,200 |  |
| 1.4.3.1.2.060 |  | backfill/compaction | 25d | 2011-12-17 A | 2012-01-08 A | 1.4.3.1.2.030 SS | 100% |  |  |  |  |  | SSH-Construction Manhours [234.44 h]; Dump Truck [200 h]; Compactor [200 h] | 94,010 | 0.0277702463 |
|  | 2 | **Structural Works** |  | 2011-10-08 | 2012-11-05 |  |  |  |  |  |  |  |  |  |  |
| 1.4.3.1.2.040 |  | Install RSB/FW/concrete for equipment fdns | 50d | 2011-10-08 A | 2012-10-31 | 1.4.3.1.2.060 FF | 40% | 30d | 2011-10-08 | 2011-11-22 | -71.25d | 0d | SSH-Construction Manhours [2936.1 h] | 41,600 |  |
| 1.4.3.1.2.020 |  | Install RSB/FW/concrete fdns | 50d | 2011-11-22 A | 2012-01-07 A | 1.4.3.1.2.010 SS+15d | 100% |  | 2011-08-22 | 2011-10-06 |  |  | SSH-Construction Manhours [2933.17 h] | 49,920 |  |
| 1.4.3.1.2.030 |  | Install RSB/FW/concrete for ground beams | 50d | 2011-12-10 A | 2012-01-15 A | 1.4.3.1.2.020 SS+25d | 100% |  | 2011-09-14 | 2011-10-30 |  |  | SSH-Construction Manhours [2941.94 h] | 21,840 |  |
| 1.4.3.1.2.050 |  | Install RSB/FW/concrete for SS5 columns | 50d | 2012-02-18 A | 2012-04-03 A | 1.4.3.1.2.040 SS+10d | 100% |  |  |  |  |  | SSH-Construction Manhours [2936.1 h] | 27,040 |  |
| 1.4.3.1.2.070 |  | Install RSB/FW/concrete for roof beams | 50d | 2012-02-27 A | 2012-04-12 A | 1.4.3.1.2.050 SS+10d | 100% |  |  |  |  |  | SSH-Construction Manhours [2936.1 h] | 66,560 |  |
| 1.4.3.1.2.080 |  | Install RSB/FW/concrete for SS5 roof slab | 50d | 2012-03-07 A | 2012-11-05 | 1.4.3.1.2.070 SS+10d | 30% | 35d | 2012-03-07 | 2012-04-22 | -71.25d | 0d | SSH-Construction Manhours [2936.1 h] | 569,500 |  |
| 1.4.3.1.2.090 |  | Install CMU blocks | 40d | 2012-04-18 A | 2012-05-24 A | 1.4.3.1.2.080 SS+45d | 100% |  |  |  |  |  | SSH-Construction Manhours [1127.78 h] | 78,660 | 0.0232359065 |

| ID | WBS | Activity | Duration | Start | Finish | Predecessors | Complete | Remaining | Planned start | Planned finish | Total float | Free float | Resources | Cost | QTY |
| --- | --- | --- | --- | --- | --- | --- | --- | --- | --- | --- | --- | --- | --- | --- | --- |
|  | 3 | **Architectural Works** |  | 2012-05-02 | 2012-11-10 |  |  |  |  |  |  |  |  |  |  |
| 1.4.3.1.2.100 |  | Install Plastering work | 40d | 2012-05-02 A | 2012-10-11 | 1.4.3.1.2.090 SS+15d | 81% | 7.6d | 2012-05-02 | 2012-06-07 | -57d | 0d | SSH-Construction Manhours [939.53 h] | 45,000 |  |
| 1.4.3.1.2.110 |  | Install finishing finishing works - [Tiling] | 30d | 2012-05-16 A | 2012-10-31 | 1.4.3.1.2.100 SS+15d |  | 30d | 2012-05-16 | 2012-06-12 | -12d | 0d | SSH-Construction Manhours [563.6 h] | 75,500 |  |
| 1.4.3.1.2.120 |  | Install wall finishing works | 30d | 2012-10-04 | 2012-10-31 | 1.4.3.1.2.110 SS+10d |  |  |  |  | -12d | 0d | SSH-Construction Manhours [563.6 h] | 88,000 |  |
| 1.4.3.1.2.125 |  | Install ceiling finishing works | 30d | 2012-10-04 | 2012-10-31 | 1.4.3.1.2.120 SS |  |  |  |  | 13d | 25d | SSH-Construction Manhours [422.7 h] | 45,000 | 0.0044309509 |
| 1.4.3.1.2.130 |  | Install roof water proofing system | 22.5d | 2012-10-14 | 2012-11-03 | 1.4.3.1.2.120 SS+10d |  |  |  |  | -12d | 0d | SSH-Construction Manhours [211.64 h] | 110,600 |  |
| 1.4.3.1.2.140 |  | Install painting works | 15d | 2012-10-23 | 2012-11-05 | 1.4.3.1.2.130 SS+10d |  |  |  |  | -12d | 0d | SSH-Construction Manhours [175.98 h] | 50,000 |  |
| 1.4.3.1.2.150 |  | Install doors & windows with frames | 15d | 2012-10-28 | 2012-11-10 | 1.4.3.1.2.140 SS+5d, 1.4.3.1.2.125 SS |  |  |  |  | -12d | 59.25d | SSH-Construction Manhours [140.9 h] | 72,400 |  |
|  | 4 | **Plumbing Works** |  | 2012-05-19 | 2012-11-04 |  |  |  |  |  |  |  |  |  |  |
| 1.4.3.1.2.210 |  | Install plumbing works | 37.5d | 2012-05-19 A | 2012-11-04 | 1.4.3.1.2.090 SS+15d, 1.3.4.7.030 | 10% | 33.75d | 2012-05-19 | 2012-06-23 | -71.25d | 0d | SSH-Construction Manhours [657.14 h] | 25,500 |  |
| 1.4.3.1.2.220 |  | Install eye wash & shower | 30d | 2012-10-04 | 2012-10-31 | 1.4.3.1.2.210 SS+25d |  |  |  |  | -2d | 69.25d | SSH-Construction Manhours [422.7 h] | 6,750 | 0.0019939279 |
|  | 5 | **Mechanical / HVAC Works** |  | 2012-10-04 | 2013-01-03 |  |  |  |  |  |  |  |  |  |  |
| 1.4.3.1.2.330 |  | Install ducting works | 45d | 2012-10-04 | 2012-11-14 | 1.4.3.1.2.210 SS |  |  |  |  | -71.25d | 0d | SSH-Construction Manhours [1125.45 h] | 35,000 |  |
| 1.4.3.1.2.340 |  | Install air inlet & outlet accs | 20d | 2012-10-28 | 2012-11-14 | 1.4.3.1.2.330 SS+25d |  |  |  |  | -70d | 0d | SSH-Construction Manhours [469.47 h] | 25,000 |  |
| 1.4.3.1.2.350 |  | Install fire & volume dampers | 20d | 2012-11-06 | 2012-11-24 | 1.4.3.1.2.340 SS+10d |  |  |  |  | -70d | 0d | SSH-Construction Manhours [281.8 h] | 25,000 |  |
| 1.4.3.1.2.360 |  | Install sandtrap louvers | 17.5d | 2012-11-15 | 2012-12-01 | 1.4.3.1.2.350 SS+10d |  |  |  |  | -70d | 0d | SSH-Construction Manhours [205.21 h] | 5,600 |  |
| 1.4.3.1.2.370 |  | Install exhaust fan | 10d | 2012-11-25 | 2012-12-03 | 1.4.3.1.2.360 SS+10d |  |  |  |  | -70d | 0d | SSH-Construction Manhours [117.51 h] | 7,595 |  |
| 1.4.3.1.2.380 |  | Install fire extinguishers | 15d | 2012-11-25 | 2012-12-08 | 1.4.3.1.2.370 SS |  |  |  |  | -42d | 29.25d | SSH-Construction Manhours [281.8 h] | 15,500 |  |
| 1.4.3.1.2.310 |  | Install ACCU equipments | 15d | 2012-11-28 | 2012-12-12 | 1.4.3.1.2.370 SS+4d |  |  |  |  | -70d | 0d | SSH-Construction Manhours [351.96 h] | 350,000 |  |
| 1.4.3.1.2.320 |  | Install AHU equipments with DDC Panel | 15d | 2012-12-12 | 2012-12-26 | 1.4.3.1.2.310 SS+15d |  |  |  |  | -70d | 0d | SSH-Construction Manhours [351.96 h] | 340,000 |  |
| 1.4.3.1.2.390 |  | Testing & balancing of HVAC system | 15d | 2012-12-20 | 2013-01-03 | 1.4.3.1.2.320 SS+9d |  |  |  |  | -70d | 1.25d | SSH-Construction Manhours [264.26 h] | 7,500 | 0.0022154755 |
|  | 6 | **Electrical Works** |  | 2012-05-19 | 2013-01-06 |  |  |  |  |  |  |  |  |  |  |
| 1.4.3.1.2.410 |  | Install electrical conduits & fititings | 45d | 2012-05-19 A | 2012-11-08 | 1.4.3.1.2.330 SS | 15% | 38.25d | 2012-05-19 | 2012-06-30 | -71.25d | 0d | SSH-Construction Manhours [845.4 h] | 25,000 |  |
| 1.4.3.1.2.500 |  | Install grounding system | 25d | 2012-07-02 A | 2012-07-25 A | 1.4.3.1.2.480 SS+47.5d | 100% |  |  |  |  |  | SSH-Construction Manhours [281.8 h] | 45,000 |  |
| 1.4.3.1.2.480 |  | Install cables trays | 60d | 2012-10-04 | 2012-11-28 | 1.4.3.1.2.410 SS |  |  |  |  | -71.25d | 0d | SSH-Construction Manhours [563.01 h] | 35,000 |  |
| 1.4.3.1.2.420 |  | Install cables & wires | 37.5d | 2012-10-30 | 2012-12-03 | 1.4.3.1.2.480 FF+5d |  |  |  |  | -71.25d | 0d | SSH-Construction Manhours [563.6 h] | 15,000 |  |
| 1.4.3.1.2.430 |  | Install lighting fixtures | 37.5d | 2012-11-04 | 2012-12-08 | 1.4.3.1.2.420 FF+5d |  |  |  |  | -71.25d | 0d | SSH-Construction Manhours [317.46 h] | 72,000 |  |
| 1.4.3.1.2.460 |  | Install RMU | 18.75d | 2012-11-29 | 2012-12-17 | 1.4.3.1.2.450 FF+3.75d |  |  |  |  | -71.25d | 0d | SSH-Construction Manhours [375.34 h] | 26,000 |  |
| 1.4.3.1.2.440 |  | Install switchgear | 7.5d | 2012-12-04 | 2012-12-11 | 1.4.3.1.2.430 FF+3d |  |  |  |  | -71.25d | 0d | SSH-Construction Manhours [281.8 h] | 52,000 |  |
| 1.4.3.1.2.490 |  | Install FAS-Fire Alarm System & FACP | 18.75d | 2012-12-05 | 2012-12-23 | 1.4.3.1.2.470 FF+3d |  |  |  |  | -71.25d | 0d | SSH-Construction Manhours [440.24 h] | 65,000 |  |
| 1.4.3.1.2.450 |  | Install package substation | 7.5d | 2012-12-06 | 2012-12-13 | 1.4.3.1.2.440 FF+3d |  |  |  |  | -71.25d | 0d | SSH-Construction Manhours [375.34 h] | 20,750 |  |
| 1.4.3.1.2.470 |  | Install Transformer | 12.5d | 2012-12-09 | 2012-12-20 | 1.4.3.1.2.460 FF+3d |  |  |  |  | -71.25d | 0d | SSH-Construction Manhours [375.34 h] | 32,500 |  |
| 1.4.3.1.2.510 |  | Install switchboard | 7.5d | 2012-12-19 | 2012-12-25 | 1.4.3.1.2.490 FF+3d |  |  |  |  | -71.25d | 0d | SSH-Construction Manhours [375.34 h] | 210,000 |  |
| 1.4.3.1.2.520 |  | Install Main distribution panel board | 7.5d | 2012-12-20 | 2012-12-27 | 1.4.3.1.2.510 FF+2d |  |  |  |  | -71.25d | 0d | SSH-Construction Manhours [375.34 h] | 60,000 |  |
| 1.4.3.1.2.530 |  | Install circuit breaker | 7.5d | 2012-12-23 | 2012-12-30 | 1.4.3.1.2.520 FF+2d |  |  |  |  | -71.25d | 0d | SSH-Construction Manhours [375.34 h] | 39,000 |  |
| 1.4.3.1.2.540 |  | Install annunciator panel | 7.5d | 2012-12-24 | 2012-12-31 | 1.4.3.1.2.530 FF+2d |  |  |  |  | -71.25d | 0d | SSH-Construction Manhours [375.34 h] | 20,000 |  |
| 1.4.3.1.2.550 |  | Install batterybank & battery charger | 7.5d | 2012-12-26 | 2013-01-02 | 1.4.3.1.2.540 FF+2d |  |  |  |  | -71.25d | 0d | SSH-Construction Manhours [281.8 h] | 100,000 |  |
| 1.4.3.1.2.560 |  | Testing /commissioning of electrical system | 10d | 2012-12-26 | 2013-01-05 | 1.4.3.1.2.550 SS, 1.4.3.1.2.540 SS |  |  |  |  | -71.25d | 0d | SSH-Construction Manhours [264.26 h] | 150,000 |  |
| 1.4.3.1.2.570 |  | Energize Substation 5 | 2d | 2013-01-05 | 2013-01-06 | 1.4.3.1.2.560, 1.4.3.1.2.380, 1.4.3.1.2.390, 1.4.3.1.2.640, 1.4.3.1.2.780, 1.4.3.1.2.150, 1.4.3.1.2.220, 1.4.3.1.2.500 |  |  |  |  | -71.25d | 26.25d | SSH-Construction Manhours [70.16 h] | 20,000 | 0.0059079345 |

| ID | WBS | Activity | Duration | Start | Finish | Predecessors | Complete | Remaining | Planned start | Planned finish | Total float | Free float | Resources | Cost | QTY |
| --- | --- | --- | --- | --- | --- | --- | --- | --- | --- | --- | --- | --- | --- | --- | --- |
|  | 7 | **Communication Works** |  | 2012-05-19 | 2012-12-22 |  |  |  |  |  |  |  |  |  |  |
| 1.4.3.1.2.610 |  | Install comm conduits & fittings | 50d | 2012-05-19 A | 2012-10-27 | 1.4.3.1.2.410 SS | 50% | 25d | 2012-05-19 | 2012-07-04 | -12d | 0d | SSH-Construction Manhours [563.01 h] | 17,000 |  |
| 1.4.3.1.2.620 |  | Install comm cabinet & accs & data interworks | 20d | 2012-10-04 | 2012-10-22 | 1.4.3.1.2.610 SS+40d |  |  |  |  | -12d | 0d | SSH-Construction Manhours [281.8 h] | 75,500 |  |
| 1.4.3.1.2.630 |  | Install comm equipments & accs | 20d | 2012-10-18 | 2012-11-05 | 1.4.3.1.2.620 SS+15d |  |  |  |  | -12d | 45d | SSH-Construction Manhours [563.01 h] | 185,000 |  |
| 1.4.3.1.2.640 |  | Install comm outlet & accs | 10d | 2012-12-13 | 2012-12-22 | 1.4.3.1.2.630 SS+15d, 1.4.3.1.2.820 |  |  |  |  | -57d | 14.25d | SSH-Construction Manhours [235.03 h] | 3,000 | 0.0008861902 |
|  | 8 | **Pavement / Parking / Signs / Markings** |  | 2012-10-04 | 2012-12-08 |  |  |  |  |  |  |  |  |  |  |
| 1.4.3.1.2.710 |  | Install gravel pavement | 40d | 2012-10-04 | 2012-11-10 | 1.4.3.1.2.100 SS |  |  |  |  | -57d | 0d | SSH-Construction Manhours [1033.07 h] | 5,467 |  |
| 1.4.3.1.2.720 |  | Install 150mm thick concrete pavement | 30d | 2012-10-23 | 2012-11-19 | 1.4.3.1.2.710 FF+10d |  |  |  |  | -41d | 0d | SSH-Construction Manhours [705.08 h] | 36,110 |  |
| 1.4.3.1.2.730 |  | Install 500mm thick general fill | 30d | 2012-10-23 | 2012-11-19 | 1.4.3.1.2.720 FF |  |  |  |  | -41d | 0d | SSH-Construction Manhours [633.17 h] | 17,400 |  |
| 1.4.3.1.2.740 |  | Install 200mm thk aggregate base coarse | 25d | 2012-11-01 | 2012-11-24 | 1.4.3.1.2.730 SS+10d |  |  |  |  | -41d | 0d | SSH-Construction Manhours [633.17 h] | 9,048 |  |
| 1.4.3.1.2.750 |  | Install 120mm thk asphalt cncrt pavement | 20d | 2012-11-11 | 2012-11-28 | 1.4.3.1.2.740 SS+10d |  |  |  |  | -41d | 0d | SSH-Construction Manhours [235.03 h] | 27,840 |  |
| 1.4.3.1.2.760 |  | Install shaded parking space | 18.75d | 2012-11-15 | 2012-12-02 | 1.4.3.1.2.750 SS+5d |  |  |  |  | -41d | 0d | SSH-Construction Manhours [264.26 h] | 56,700 |  |
| 1.4.3.1.2.770 |  | Install road / park markings | 15d | 2012-11-20 | 2012-12-04 | 1.4.3.1.2.760 SS+6d |  |  |  |  | -41d | 0d | SSH-Construction Manhours [211.64 h] | 37,500 |  |
| 1.4.3.1.2.780 |  | Install road / parking signs | 15d | 2012-11-24 | 2012-12-08 | 1.4.3.1.2.770 SS+3d |  |  |  |  | -41d | 30.25d | SSH-Construction Manhours [211.64 h] | 7,560 | 0.0022331993 |
|  | 9 | **Perimeter Fence System** |  | 2012-10-28 | 2012-12-12 |  |  |  |  |  |  |  |  |  |  |
| 1.4.3.1.2.810 |  | Install perimeter fence type SSD-1 | 45d | 2012-10-28 | 2012-12-08 | 1.4.3.1.2.710 SS+25d |  |  |  |  | -57d | 0d | SSH-Construction Manhours [527.94 h] | 82,350 |  |
| 1.4.3.1.2.820 |  | Install periemter gate SSD-1 10.5m wide 2 leaf | 20d | 2012-11-25 | 2012-12-12 | 1.4.3.1.2.810 SS+30d |  |  |  |  | -57d | 0d | SSH-Construction Manhours [235.03 h] | 15,000 | 0.0044309509 |
|  | 2 | **Exchange Building** |  | 2011-10-02 | 2013-03-05 |  |  |  |  |  |  |  |  |  |  |
|  | 1 | **Exchange Building** |  | 2011-10-02 | 2013-03-05 |  |  |  |  |  |  |  |  |  |  |
|  | 1 | **Civil Works** |  | 2011-10-02 | 2012-01-02 |  |  |  |  |  |  |  |  |  |  |
| 1.4.3.2.1.010 |  | Site clearing / grubbing | 15d | 2011-10-02 A | 2011-10-29 A | 1.2.6.200 SS+18.75d, 1.4.1.3.4.010 SS | 100% |  | 2011-07-26 | 2011-08-08 |  |  | SSH-Construction Manhours [305 h]; Grader [120 h]; Dump Truck [120 h] | 24,300 |  |
| 1.4.3.2.1.020 |  | Excavation leveling & compactionfor exchange bldg 1 fdns | 15d | 2011-10-31 A | 2011-11-28 A | 1.4.3.2.1.010 SS+6d | 100% |  | 2011-07-31 | 2011-08-14 |  |  | SSH-Construction Manhours [623.91 h]; Excavator [120 h]; Dump Truck [120 h] | 21,750 |  |
| 1.4.3.2.1.030 |  | Backfill/compaction of exchange bldg fdns | 18.75d | 2011-12-05 A | 2012-01-02 A | 1.4.3.2.1.110 FF | 100% |  | 2011-12-15 | 2012-01-02 |  |  | SSH-Construction Manhours [449.53 h]; Dump Truck [150 h]; Compactor [150 h] | 257,500 | 0.0760646572 |
|  | 2 | **Structural Works** |  | 2011-12-26 | 2013-01-17 |  |  |  |  |  |  |  |  |  |  |
| 1.4.3.2.1.110 |  | Install RSB/FW/concrete for fdns | 30d | 2011-12-26 A | 2012-01-17 A | 1.4.3.2.1.020 | 100% |  | 2011-08-14 | 2011-09-11 |  |  | SSH-Construction Manhours [7016.98 h] | 164,320 |  |
| 1.4.3.2.1.120 |  | Install RSB/FW/concrete for ground beams | 30d | 2012-01-15 A | 2012-02-11 A | 1.4.3.2.1.030 FF | 100% |  |  |  |  |  | SSH-Construction Manhours [7484.26 h] | 20,800 |  |
| 1.4.3.2.1.170 |  | Install RSB/FW/cncrt for cable vault, SOG | 30d | 2012-01-15 A | 2012-02-11 A | 1.4.3.2.1.120 SS | 100% |  |  |  |  |  | SSH-Construction Manhours [4491.08 h] | 58,240 |  |
| 1.4.3.2.1.130 |  | Install RSB/FW/concrete for equipment fdns | 30d | 2012-02-18 A | 2012-10-17 | 1.4.3.2.1.120 FF+5d | 52% | 14.4d | 2012-02-18 | 2012-03-15 | -69.8d | 0d | SSH-Construction Manhours [7484.26 h] | 10,400 |  |
| 1.4.3.2.1.140 |  | Install RSB/FW/concrete for columns | 30d | 2012-03-07 A | 2012-04-03 A | 1.4.3.2.1.130 FF+20d | 100% |  |  |  |  |  | SSH-Construction Manhours [7484.26 h] | 6,240 |  |
| 1.4.3.2.1.230 |  | Install embedded structural steel, anchor bolts,plates,angles | 120d | 2012-03-17 A | 2013-01-17 | 1.4.3.2.1.130 SS+30d | 6% | 112.8d | 2012-03-17 | 2012-07-05 | -69.8d | 0d | SSH-Construction Manhours [5172.94 h] | 617,500 |  |
| 1.4.3.2.1.190 |  | Install 150mm thk prefabricated wall panel | 25d | 2012-03-18 A | 2012-11-14 | 1.4.3.2.1.170 FF+15d, 1.4.3.2.1.180 FF+15d | 15% | 21.25d | 2012-03-18 | 2012-04-10 | -129.5d | 0d | SSH-Construction Manhours [2585.95 h] | 273,000 |  |
| 1.4.3.2.1.150 |  | Install RSB/FW/concrete for side walls | 30d | 2012-03-21 A | 2012-04-17 A | 1.4.3.2.1.140 FF+15d | 100% |  |  |  |  |  | SSH-Construction Manhours [5986.88 h] | 67,600 |  |
| 1.4.3.2.1.155 |  | Install structural steel structures | 30d | 2012-03-21 A | 2012-12-02 | 1.4.3.2.1.150 SS | 3% | 29.25d | 2012-03-21 | 2012-04-17 | -31.9d | 0d | SSH-Construction Manhours [4491.08 h] | 700,000 | 0.2953967271 |
| 1.4.3.2.1.200 |  | Install 250mm thk prefabricated wall panel | 25d | 2012-03-27 A | 2012-11-24 | 1.4.3.2.1.190 FF+10d | 15% | 21.25d | 2012-03-27 | 2012-04-19 | -103d | 0d | SSH-Construction Manhours [1497.37 h] | 690,000 |  |
| 1.4.3.2.1.160 |  | Install RSB/FW/cncrt for suspended slab | 30d | 2012-04-04 A | 2012-11-19 | 1.4.3.2.1.150 FF+15d, 1.4.3.2.1.155 SS | 50% | 15d | 2012-04-04 | 2012-05-01 | -31.9d | 37.9d | SSH-Construction Manhours [5986.88 h] | 15,600 |  |
| 1.4.3.2.1.210 |  | Install 250mm thk prefabricated wall panel, 150mm thkx650mm | 30d | 2012-04-05 A | 2012-12-08 | 1.4.3.2.1.200 FF+15d | 15% | 25.5d | 2012-04-05 | 2012-05-03 | -103d | 0d | SSH-Construction Manhours [1497.37 h] | 795,000 |  |
| 1.4.3.2.1.220 |  | Install expanded wire mesh on frame as per SSD/20 | 30d | 2012-06-09 A | 2013-01-17 | 1.4.3.2.1.210 FF, 1.4.3.2.1.230 FF, 1.4.3.2.1.160 | 15% | 25.5d | 2012-06-09 | 2012-07-05 | -69.8d | 0d | SSH-Construction Manhours [2585.95 h] | 148,500 |  |
| 1.4.3.2.1.180 |  | Install RSB/FW/cncrt for grade slab | 30d | 2012-10-04 | 2012-10-31 | 1.4.3.2.1.170 FF+15d |  |  |  |  | -129.5d | 0d | SSH-Construction Manhours [3367.52 h] | 3,120 |  |

| ID | WBS | Activity | Duration | Start | Finish | Predecessors | Complete | Remaining | Planned start | Planned finish | Total float | Free float | Resources | Cost | QTY |
| --- | --- | --- | --- | --- | --- | --- | --- | --- | --- | --- | --- | --- | --- | --- | --- |
|  | 3 | **Architectural Works** |  | 2012-03-18 | 2013-03-04 |  |  |  |  |  |  |  |  |  |  |
|  | 1 | **Masonry work** |  | 2012-03-18 | 2012-11-04 |  |  |  |  |  |  |  |  |  |  |
| 1.4.3.2.1.310 |  | Install 200mm thk CMU blocks | 37.5d | 2012-03-18 A | 2012-04-22 A | 1.4.3.2.1.190 SS | 100% |  |  |  |  |  | SSH-Construction Manhours [2391.2 h] | 425,000 |  |
| 1.4.3.2.1.320 |  | Install 50mm thk morter plastering work | 37.5d | 2012-03-22 A | 2012-11-04 | 1.4.3.2.1.310 FF+5d | 12% | 33d | 2012-03-22 | 2012-04-26 | -138.75d | 0d | SSH-Construction Manhours [1793.92 h] | 354,100 | 0.0174284069 |
|  | 2 | **Floor Finishing work** |  | 2012-12-24 | 2013-01-26 |  |  |  |  |  |  |  |  |  |  |
| 1.4.3.2.1.330 |  | Install ceramic tiling works | 20d | 2012-12-24 | 2013-01-12 | 1.4.3.2.1.380 SS |  |  |  |  | -69.8d | 0d | SSH-Construction Manhours [898.53 h] | 51,000 |  |
| 1.4.3.2.1.340 |  | Install cement toping works | 20d | 2012-12-29 | 2013-01-16 | 1.4.3.2.1.330 FF+5d |  |  |  |  | -69.8d | 0d | SSH-Construction Manhours [898.53 h] | 50,000 |  |
| 1.4.3.2.1.350 |  | Install vinyl tiling works | 20d | 2013-01-02 | 2013-01-21 | 1.4.3.2.1.340 FF+5d |  |  |  |  | -69.8d | 0d | SSH-Construction Manhours [898.53 h] | 40,800 |  |
| 1.4.3.2.1.360 |  | Install APCS-12 painting works | 20d | 2013-01-07 | 2013-01-26 | 1.4.3.2.1.350 FF+5d |  |  |  |  | -69.8d | 0d | SSH-Construction Manhours [798.29 h] | 35,250 |  |
| 1.4.3.2.1.370 |  | Install accs floor system | 12d | 2013-01-15 | 2013-01-26 | 1.4.3.2.1.360 FF |  |  |  |  | -69.8d | 0d | SSH-Construction Manhours [479.28 h] | 205,000 | 0.0516944272 |
|  | 3 | **Wall Finishing work** |  | 2012-12-24 | 2013-01-26 |  |  |  |  |  |  |  |  |  |  |
| 1.4.3.2.1.380 |  | Install dry wall partition works | 25d | 2012-12-24 | 2013-01-16 | 1.4.3.2.1.220 SS, 1.3.1.13.030, 1.3.1.12.030 |  |  |  |  | -69.8d | 0d | SSH-Construction Manhours [1121.99 h] | 117,750 |  |
| 1.4.3.2.1.390 |  | Install ceramic wall tiling works | 25d | 2012-12-29 | 2013-01-21 | 1.4.3.2.1.380 FF+5d |  |  |  |  | -44.8d | 0d | SSH-Construction Manhours [1121.99 h] | 43,500 |  |
| 1.4.3.2.1.400 |  | Install wall painting works | 25d | 2013-01-02 | 2013-01-26 | 1.4.3.2.1.390 FF+5d |  |  |  |  | -44.8d | 10d | SSH-Construction Manhours [997.73 h] | 90,750 | 0.0179453512 |
|  | 4 | **Ceiling Finishing work** |  | 2013-01-26 | 2013-02-27 |  |  |  |  |  |  |  |  |  |  |
| 1.4.3.2.1.410 |  | Install acoustical celing works | 25d | 2013-01-26 | 2013-02-18 | 1.4.3.2.1.400 SS, 1.4.3.2.1.370, 1.3.1.11.030 |  |  |  |  | -69.8d | 0d | SSH-Construction Manhours [997.73 h] | 40,925 |  |
| 1.4.3.2.1.420 |  | Install gypsum board celing works | 25d | 2013-01-30 | 2013-02-23 | 1.4.3.2.1.410 FF+5d |  |  |  |  | -54.8d | 0d | SSH-Construction Manhours [748.16 h] | 36,300 |  |
| 1.4.3.2.1.430 |  | Install ceiling painting works | 25d | 2013-02-04 | 2013-02-27 | 1.4.3.2.1.420 FF+5d, 1.4.3.2.1.400 |  |  |  |  | -54.8d | 15d | SSH-Construction Manhours [748.16 h] | 52,050 | 0.0065134978 |
|  | 5 | **Roof Finishing work** |  | 2013-02-09 | 2013-03-04 |  |  |  |  |  |  |  |  |  |  |
| 1.4.3.2.1.440 |  | Install roof water proofing system | 15d | 2013-02-09 | 2013-02-23 | 1.4.3.2.1.410 SS+15d |  |  |  |  | -69.8d | 0d | SSH-Construction Manhours [623.91 h] | 195,000 |  |
| 1.4.3.2.1.450 |  | Install roof painting works | 15d | 2013-02-18 | 2013-03-04 | 1.4.3.2.1.440 FF+10d |  |  |  |  | -69.8d | 0d | SSH-Construction Manhours [499.65 h] | 52,400 | 0.0066168867 |
|  | 6 | **Doors & Windows** |  | 2013-02-18 | 2013-03-04 |  |  |  |  |  |  |  |  |  |  |
| 1.4.3.2.1.460 |  | Install doors & windows with frames | 15d | 2013-02-18 | 2013-03-04 | 1.4.3.2.1.450 SS, 1.4.3.2.1.430 SS, 1.4.3.2.1.030 |  |  |  |  | -69.8d | 0d | SSH-Construction Manhours [623.91 h] | 119,600 | 0.0264675467 |
|  | 4 | **Plumbing Works** |  | 2012-11-06 | 2012-12-26 |  |  |  |  |  |  |  |  |  |  |
| 1.4.3.2.1.510 |  | Install plumbing system & fittings | 35d | 2012-11-06 | 2012-12-08 | 1.4.3.2.1.210 FF |  |  |  |  | -103d | 0d | SSH-Construction Manhours [1047.85 h] | 110,000 |  |
| 1.4.3.2.1.520 |  | Install plumbing fixtures | 15d | 2012-12-04 | 2012-12-17 | 1.4.3.2.1.510 FF+10d |  |  |  |  | -16.25d | 0d | SSH-Construction Manhours [898.53 h] | 45,500 |  |
| 1.4.3.2.1.530 |  | Install countertop w/built in lavatory | 15d | 2012-12-13 | 2012-12-26 | 1.4.3.2.1.520 FF+10d |  |  |  |  | -16.25d | 53.55d | SSH-Construction Manhours [798.29 h] | 39,500 | 0.0028062689 |

| ID | WBS | Activity | Duration | Start | Finish | Predecessors | Complete | Remaining | Planned start | Planned finish | Total float | Free float | Resources | Cost | QTY |
| --- | --- | --- | --- | --- | --- | --- | --- | --- | --- | --- | --- | --- | --- | --- | --- |
|  | 5 | **Mechanical / HVAC Works** |  | 2012-10-28 | 2013-03-04 |  |  |  |  |  |  |  |  |  |  |
| 1.4.3.2.1.630 |  | Install ducting system | 45d | 2012-10-28 | 2012-12-08 | 1.4.3.2.1.310 FF, 1.3.4.15.030, 1.4.3.2.1.510 FF |  |  |  |  | -103d | 0d | SSH-Construction Manhours [1798.62 h] | 150,000 |  |
| 1.4.3.2.1.640 |  | Install air & outlets accs | 25d | 2012-11-25 | 2012-12-17 | 1.4.3.2.1.630 FF+10d |  |  |  |  | -39.25d | 0d | SSH-Construction Manhours [997.73 h] | 85,000 |  |
| 1.4.3.2.1.650 |  | Install fire / volume dampers | 25d | 2012-12-04 | 2012-12-26 | 1.4.3.2.1.640 FF+10d |  |  |  |  | -39.25d | 0d | SSH-Construction Manhours [997.73 h] | 85,000 |  |
| 1.4.3.2.1.610 |  | Install ACCU equipments | 25d | 2012-12-16 | 2013-01-08 | 1.4.3.2.1.680 FF+4d |  |  |  |  | -39.25d | 0d | SSH-Construction Manhours [1121.99 h] | 850,000 |  |
| 1.4.3.2.1.660 |  | Install sandtrap louvers | 15d | 2012-12-18 | 2012-12-31 | 1.4.3.2.1.650 FF+5d |  |  |  |  | -39.25d | 0d | SSH-Construction Manhours [598.85 h] | 16,200 |  |
| 1.4.3.2.1.620 |  | Install AHU equipments | 25d | 2012-12-25 | 2013-01-17 | 1.4.3.2.1.610 FF+10d |  |  |  |  | -39.25d | 30.55d | SSH-Construction Manhours [1121.99 h] | 510,000 |  |
| 1.4.3.2.1.670 |  | Install exhaust fan | 5d | 2012-12-29 | 2013-01-02 | 1.4.3.2.1.660 FF+2d, 1.3.4.16.030 |  |  |  |  | -39.25d | 0d | SSH-Construction Manhours [300.21 h] | 15,000 |  |
| 1.4.3.2.1.680 |  | Install fire protection system | 5d | 2012-12-31 | 2013-01-05 | 1.4.3.2.1.670 FF+2d |  |  |  |  | -39.25d | 0d | SSH-Construction Manhours [199.44 h] | 75,500 |  |
| 1.4.3.2.1.685 |  | Install fire extinguishers | 5d | 2013-01-01 | 2013-01-06 | 1.4.3.2.1.680 FF+2d |  |  |  |  | -8.5d | 61.3d | SSH-Construction Manhours [199.44 h] | 15,500 | 0.0045786493 |
| 1.4.3.2.1.690 |  | Testing & balancing of HVAC system | 18.75d | 2013-02-14 | 2013-03-04 | 1.4.3.2.1.620, 1.4.3.2.1.685 FF, 1.4.3.2.1.530, 1.4.3.2.1.460 FF |  |  |  |  | -69.8d | 0d | SSH-Construction Manhours [561.78 h] | 15,000 |  |
|  | 6 | **Electrical Works** |  | 2012-05-09 | 2013-02-17 |  |  |  |  |  |  |  |  |  |  |
| 1.4.3.2.1.710 |  | Install electrical conduits / fittings | 30d | 2012-05-09 A | 2012-12-08 | 1.4.3.2.1.630 FF | 10% | 27d | 2012-05-09 | 2012-06-05 | -103d | 0d | SSH-Construction Manhours [1196.12 h] | 61,030 |  |
| 1.4.3.2.1.720 |  | Install cables / wires | 25d | 2012-11-13 | 2012-12-06 | 1.4.3.2.1.710 SS+10d |  |  |  |  | -86d | 0d | SSH-Construction Manhours [997.73 h] | 25,000 |  |
| 1.4.3.2.1.730 |  | Install lighting fixtures | 25d | 2012-11-27 | 2012-12-20 | 1.4.3.2.1.720 SS+15d |  |  |  |  | -86d | 0d | SSH-Construction Manhours [623.91 h] | 160,000 |  |
| 1.4.3.2.1.740 |  | Install panelboards | 10d | 2012-12-11 | 2012-12-20 | 1.4.3.2.1.730 FF |  |  |  |  | -86d | 0d | SSH-Construction Manhours [249.56 h] | 15,000 |  |
| 1.4.3.2.1.750 |  | Install lighting control panel | 10d | 2012-12-15 | 2012-12-24 | 1.4.3.2.1.740 FF+4d |  |  |  |  | -86d | 0d | SSH-Construction Manhours [249.56 h] | 6,000 |  |
| 1.4.3.2.1.760 |  | Install annunciator DC distribution panel | 15d | 2012-12-15 | 2012-12-29 | 1.4.3.2.1.750 FF+5d |  |  |  |  | -86d | 0d | SSH-Construction Manhours [523.66 h] | 70,000 |  |
| 1.4.3.2.1.770 |  | Install battery bank / battery charger/UPS | 15d | 2012-12-18 | 2013-01-01 | 1.4.3.2.1.760 FF+4d, 1.3.2.14.030 |  |  |  |  | -86d | 0d | SSH-Construction Manhours [523.66 h] | 400,000 |  |
| 1.4.3.2.1.780 |  | Install inventor | 10d | 2012-12-27 | 2013-01-05 | 1.4.3.2.1.770 FF+4d, 1.3.2.26.030 |  |  |  |  | -86d | 0d | SSH-Construction Manhours [300.21 h] | 870,000 |  |
| 1.4.3.2.1.800 |  | Install disconnect switches | 15d | 2012-12-30 | 2013-01-13 | 1.4.3.2.1.790 FF+4d |  |  |  |  | -86d | 0d | SSH-Construction Manhours [449.53 h] | 5,200 |  |
| 1.4.3.2.1.790 |  | Install inventor distribution panel | 10d | 2012-12-31 | 2013-01-09 | 1.4.3.2.1.780 FF+4d |  |  |  |  | -86d | 0d | SSH-Construction Manhours [300.21 h] | 65,000 |  |
| 1.4.3.2.1.810 |  | Install FAS-Fire alarm system & FACP with detection sytem | 15d | 2013-01-02 | 2013-01-16 | 1.4.3.2.1.800 FF+4d |  |  |  |  | -86d | 0d | SSH-Construction Manhours [449.53 h] | 40,000 |  |
| 1.4.3.2.1.820 |  | Install grounding system | 15d | 2013-01-06 | 2013-01-20 | 1.4.3.2.1.810 FF+4d |  |  |  |  | -86d | 0d | SSH-Construction Manhours [449.53 h] | 45,000 |  |
| 1.4.3.2.1.830 |  | Install circuit breaker | 15d | 2013-01-10 | 2013-01-23 | 1.4.3.2.1.820 FF+4d |  |  |  |  | -86d | 0d | SSH-Construction Manhours [449.53 h] | 150,000 |  |
| 1.4.3.2.1.840 |  | Install ATS | 15d | 2013-01-14 | 2013-01-28 | 1.4.3.2.1.830 FF+4d, 1.3.2.9.030 |  |  |  |  | -86d | 0d | SSH-Construction Manhours [449.53 h] | 260,000 |  |
| 1.4.3.2.1.850 |  | Install moduler rectifier | 15d | 2013-01-17 | 2013-01-31 | 1.4.3.2.1.840 FF+4d, 1.3.2.26.030 |  |  |  |  | -86d | 0d | SSH-Construction Manhours [449.53 h] | 590,000 |  |
| 1.4.3.2.1.860 |  | Install 500kva generator | 15d | 2013-01-21 | 2013-02-04 | 1.4.3.2.1.850 FF+4d |  |  |  |  | -86d | 0d | SSH-Construction Manhours [449.53 h] | 900,000 |  |
| 1.4.3.2.1.870 |  | Install 300kva, 13.8kv XFR | 15d | 2013-01-24 | 2013-02-07 | 1.4.3.2.1.860 FF+4d |  |  |  |  | -86d | 0d | SSH-Construction Manhours [373.82 h] | 80,000 |  |
| 1.4.3.2.1.880 |  | Install switchboards | 15d | 2013-01-29 | 2013-02-11 | 1.4.3.2.1.870 FF+4d |  |  |  |  | -86d | 0d | SSH-Construction Manhours [300.21 h] | 145,000 |  |
| 1.4.3.2.1.890 |  | Testing/commissioning electrical system | 15d | 2013-02-03 | 2013-02-17 | 1.4.3.2.1.880 SS+6d |  |  |  |  | -86d | 17d | SSH-Construction Manhours [373.82 h] | 250,000 | 0.0738491818 |

| ID | WBS | Activity | Duration | Start | Finish | Predecessors | Total float | Free float | Resources | Cost | QTY |
| --- | --- | --- | --- | --- | --- | --- | --- | --- | --- | --- | --- |
|  | 7 | **MDF & Cable Vault** |  | 2012-12-09 | 2013-02-20 |  |  |  |  |  |  |
| 1.4.3.2.1.910 |  | Install comm cable vault & accs | 45d | 2012-12-09 | 2013-01-19 | 1.4.3.2.1.710, 1.3.3.6.030, 1.3.3.7.030, 1.3.3.18.030 | -103d | 0d | SSH-Construction Manhours [1798.62 h] | 15,000 |  |
| 1.4.3.2.1.920 |  | Install comm MDF | 25d | 2013-01-06 | 2013-01-28 | 1.4.3.2.1.910 SS+30d | -103d | 0d | SSH-Construction Manhours [1499.98 h] | 260,000 |  |
| 1.4.3.2.1.930 |  | Install comm equipments / accs | 25d | 2013-01-20 | 2013-02-11 | 1.4.3.2.1.920 SS+15d, 1.3.3.8.030 | -103d | 0d | SSH-Construction Manhours [1003.99 h] | 5,000 |  |
| 1.4.3.2.1.940 |  | Install comm outlets / accs | 25d | 2013-01-29 | 2013-02-20 | 1.4.3.2.1.930 SS+10d | -103d | 0d | SSH-Construction Manhours [1248.86 h] | 3,000 | 0.0008861902 |
|  | 8 | **Communication Works at Exch Bldg #1 with existing network** |  | 2012-12-13 | 2013-02-20 |  |  |  |  |  |  |
| 1.4.3.2.1.1010 |  | Install comm equip to connect with existing exch bldg | 75d | 2012-12-13 | 2013-02-20 | 1.4.3.2.1.940 FF, 1.3.3.14.030 FF | -103d | 0d | SSH-Construction Manhours [1804.37 h] | 220,000 | 0.06498728 |
|  | 9 | **Communication Works at Exch Bldg #1 with security HQ bldg** |  | 2012-12-10 | 2013-02-20 |  |  |  |  |  |  |
| 1.4.3.2.1.1110 |  | Install comm equip to connect with security HQ | 78.75d | 2012-12-10 | 2013-02-20 | 1.4.3.2.1.1010 FF | -103d | 0d | SSH-Construction Manhours [1804.37 h] | 65,000 | 0.0192007873 |
|  | 10 | **Communication Works at Exch Bldg #1 with exst bsns data center** |  | 2012-12-27 | 2013-02-20 |  |  |  |  |  |  |
| 1.4.3.2.1.1210 |  | Install comm equip to connect with exst business center | 60d | 2012-12-27 | 2013-02-20 | 1.4.3.2.1.1110 FF | -57.5d | 12.3d | SSH-Construction Manhours [537.76 h] | 95,000 | 0.0280626891 |
|  | 11 | **SACS System** |  | 2012-12-09 | 2013-03-05 |  |  |  |  |  |  |
| 1.4.3.2.1.1310 |  | Install SACS System & access | 60d | 2012-12-09 | 2013-02-02 | 1.3.3.15.030 FF, 1.4.3.2.1.910 SS | -83d | 0d | SSH-Construction Manhours [1724.49 h] | 180,000 |  |
| 1.4.3.2.1.1320 |  | Install miscellaneous items | 60d | 2012-12-09 | 2013-02-02 | 1.4.3.2.1.1310 FF | -83d | 20d | SSH-Construction Manhours [1724.49 h] | 30,000 |  |
| 1.4.3.2.1.1330 |  | Testing / commissioning SACS system | 30d | 2013-01-27 | 2013-02-24 | 1.4.3.2.1.1320 FF+3d, 1.4.3.2.1.1010 FF+3d, 1.4.3.2.1.1110 FF+3d | -103d | 0d | SSH-Construction Manhours [149.32 h] | 5,000 |  |
| 1.4.3.2.1.1340 |  | Energize SACS System & Communication Bldg | 10d | 2013-02-24 | 2013-03-05 | 1.4.3.2.1.1330 | -103d | 0d | SSH-Construction Manhours [149.32 h] | 5,000 | 0.0014769836 |
|  | 12 | **Pavement / Parking / Signs / Markings** |  | 2012-12-02 | 2013-02-02 |  |  |  |  |  |  |
| 1.4.3.2.1.1410 |  | Install gravel pavement | 30d | 2012-12-02 | 2012-12-30 | 1.4.3.2.1.320 FS+30d, 1.4.3.2.1.030 | -138.75d | 0d | SSH-Construction Manhours [748.16 h] | 40,600 |  |
| 1.4.3.2.1.1420 |  | Install 150mm thk concrete pavement | 30d | 2012-12-09 | 2013-01-06 | 1.4.3.2.1.1410 SS+8d | -94.75d | 0d | SSH-Construction Manhours [1047.85 h] | 679,650 |  |
| 1.4.3.2.1.1430 |  | Install 500mm thk general fill | 30d | 2012-12-17 | 2013-01-14 | 1.4.3.2.1.1420 SS+8d | -94.75d | 0d | SSH-Construction Manhours [748.16 h] | 73,875 |  |
| 1.4.3.2.1.1440 |  | Install 200mm thk aggregate base coarse | 30d | 2012-12-24 | 2013-01-21 | 1.4.3.2.1.1430 SS+8d | -94.75d | 0d | SSH-Construction Manhours [1207.09 h] | 76,830 |  |
| 1.4.3.2.1.1450 |  | Install 120mm thk asphalt concrete pavement | 25d | 2013-01-01 | 2013-01-23 | 1.4.3.2.1.1440 SS+8d | -94.75d | 0d | SSH-Construction Manhours [997.73 h] | 236,400 |  |
| 1.4.3.2.1.1460 |  | Install shaded parking space | 25d | 2013-01-08 | 2013-01-31 | 1.4.3.2.1.1450 SS+8d | -94.75d | 0d | SSH-Construction Manhours [798.29 h] | 48,600 |  |
| 1.4.3.2.1.1470 |  | Install road / park markings | 20d | 2013-01-08 | 2013-01-27 | 1.4.3.2.1.1460 SS | -94.75d | 0d | SSH-Construction Manhours [798.29 h] | 3,000 |  |
| 1.4.3.2.1.1480 |  | Install road / park signs | 18.75d | 2013-01-15 | 2013-02-02 | 1.4.3.2.1.1470 SS+8d | -94.75d | 0d | SSH-Construction Manhours [489.73 h] | 4,320 | 0.0012761139 |

| ID | WBS | Activity | Duration | Start | Finish | Predecessors | Complete | Remaining | Planned start | Planned finish | Total float | Free float | Resources | Cost | QTY |
| --- | --- | --- | --- | --- | --- | --- | --- | --- | --- | --- | --- | --- | --- | --- | --- |
|  | 13 | **Perimeter Fence System** |  | 2013-01-05 | 2013-02-25 |  |  |  |  |  |  |  |  |  |  |
| 1.4.3.2.1.1510 |  | Install perimeter fence type SSD-1 | 45d | 2013-01-05 | 2013-02-16 | 1.4.3.2.1.1450 SS+4d |  |  |  |  | -94d | 0.75d | SSH-Construction Manhours [2246.58 h] | 202,500 |  |
| 1.4.3.2.1.1520 |  | Install perimeter gate SSD-1, 10.5m widex2 leaf | 25d | 2013-02-02 | 2013-02-25 | 1.4.3.2.1.1510 SS+30d, 1.4.3.2.1.1480 |  |  |  |  | -94.75d | 8.25d | SSH-Construction Manhours [1248.86 h] | 18,500 | 0.0054648395 |
|  | 3 | **Toilet Facilities (3 nos)** |  | 2012-05-22 | 2013-05-07 |  |  |  |  |  |  |  |  |  |  |
|  | 1 | **Toilet # 1** |  | 2012-05-22 | 2013-04-14 |  |  |  |  |  |  |  |  |  |  |
|  | 1 | **Civil works** |  | 2012-05-24 | 2013-01-29 |  |  |  |  |  |  |  |  |  |  |
| 1.4.3.3.1.1.010 |  | Excavation leveling & compaction for toilet # 1 bldg fdns | 10d | 2012-05-24 A | 2012-06-03 A | 1.2.6.200 FS+100d, 1.4.3.2.1.1410 SS | 100% |  |  |  |  |  | SSH-Construction Manhours [206.84 h]; Excavator [80 h]; Dump Truck [80 h] | 1,250 |  |
| 1.4.3.3.1.1.020 |  | Backfilling/compation | 12.5d | 2013-01-17 | 2013-01-29 | 1.4.3.3.1.1.070 |  |  |  |  | -52.25d | 57d | SSH-Construction Manhours [132.77 h]; Dump Truck [100 h]; Compactor [100 h] | 1,225 | 0.000361861 |
|  | 2 | **Structural works** |  | 2012-05-22 | 2013-01-28 |  |  |  |  |  |  |  |  |  |  |
| 1.4.3.3.1.1.030 |  | Install lean concrete for reinforced fdns for toilet bldg | 18.75d | 2012-05-22 A | 2012-06-09 A | 1.4.3.3.1.1.010 FF+6d | 100% |  |  |  |  |  | SSH-Construction Manhours [380.14 h] | 1,050 |  |
| 1.4.3.3.1.1.040 |  | Install reinforced fdns for toilet bldg | 31.25d | 2012-06-20 A | 2012-07-19 A | 1.4.3.3.1.1.030 SS+31.25d | 100% |  |  |  |  |  | SSH-Construction Manhours [633.79 h] | 28,600 |  |
| 1.4.3.3.1.1.050 |  | Install reinforced columns | 45d | 2012-07-14 A | 2012-12-08 | 1.4.3.3.1.1.040 SS+25d | 85% | 6.75d | 2012-07-14 | 2012-08-25 | -114d | 0d | SSH-Construction Manhours [768.66 h] | 18,000 |  |
| 1.4.3.3.1.1.060 |  | Install reinforced roof beams | 45d | 2012-12-02 | 2013-01-13 | 1.4.3.3.1.1.050 SS+30d |  |  |  |  | -114d | 0d | SSH-Construction Manhours [768.66 h] | 18,000 |  |
| 1.4.3.3.1.1.070 |  | Install reinforced roof slab /paraphet | 35d | 2012-12-16 | 2013-01-17 | 1.4.3.3.1.1.060 SS+15d |  |  |  |  | -114d | 0d | SSH-Construction Manhours [768.66 h] | 26,000 |  |
| 1.4.3.3.1.1.080 |  | Install reinforced slab on grade | 31.25d | 2012-12-30 | 2013-01-28 | 1.4.3.3.1.1.070 SS+15d |  |  |  |  | -87.5d | 21.75d | SSH-Construction Manhours [723.94 h] | 14,720 | 0.0043482398 |
|  | 3 | **Architectural works** |  | 2012-09-26 | 2013-04-14 |  |  |  |  |  |  |  |  |  |  |
|  | 1 | **Masonry** |  | 2012-09-26 | 2013-02-17 |  |  |  |  |  |  |  |  |  |  |
| 1.4.3.3.1.1.090 |  | Install 200mm thk CMU blocks | 31.25d | 2012-09-26 A | 2013-02-10 | 1.4.3.3.1.1.070 | 20% | 25d | 2012-09-26 | 2012-10-25 | -114d | 0d | SSH-Construction Manhours [559.02 h] | 14,915 |  |
| 1.4.3.3.1.1.100 |  | Install 50 mm thk mortar plastering work | 31.25d | 2013-01-19 | 2013-02-17 | 1.4.3.3.1.1.090 SS+10d |  |  |  |  | -109.25d | 0d | SSH-Construction Manhours [419.27 h] | 37,100 | 0.0109592186 |
|  | 2 | **Floor Finishing** |  | 2013-03-03 | 2013-04-09 |  |  |  |  |  |  |  |  |  |  |
| 1.4.3.3.1.1.110 |  | Install cement toping work | 31.25d | 2013-03-03 | 2013-03-31 | 1.4.3.3.1.1.140 SS |  |  |  |  | -109.25d | 0d | SSH-Construction Manhours [542.95 h] | 5,500 |  |
| 1.4.3.3.1.1.120 |  | Install cermaic tiling work | 31.25d | 2013-03-12 | 2013-04-09 | 1.4.3.3.1.1.110 SS+10d, 1.4.3.3.1.1.150 SS, 1.4.3.3.1.1.020 SS |  |  |  |  | -109.25d | 91.17d | SSH-Construction Manhours [542.95 h] | 11,000 | 0.003249364 |
|  | 3 | **Wall Finishing** |  | 2013-02-24 | 2013-04-07 |  |  |  |  |  |  |  |  |  |  |
| 1.4.3.3.1.1.130 |  | Install phenolic toilet partition | 31.25d | 2013-02-24 | 2013-03-25 | 1.4.3.3.1.1.170 SS |  |  |  |  | -109.25d | 0d | SSH-Construction Manhours [361.97 h] | 70,000 |  |
| 1.4.3.3.1.1.140 |  | Install ceramic tiling work | 31.25d | 2013-03-03 | 2013-03-31 | 1.4.3.3.1.1.130 SS+7d |  |  |  |  | -109.25d | 0d | SSH-Construction Manhours [361.97 h] | 25,000 |  |
| 1.4.3.3.1.1.150 |  | Install textured painted work on CMU wall | 31.25d | 2013-03-09 | 2013-04-07 | 1.4.3.3.1.1.140 SS+7d |  |  |  |  | -106.25d | 3d | SSH-Construction Manhours [452.81 h] | 33,750 | 0.0099696395 |

| ID | WBS | Activity | Duration | Start | Finish | Predecessors | Complete | Total float | Free float | Resources | Cost | QTY |
| --- | --- | --- | --- | --- | --- | --- | --- | --- | --- | --- | --- | --- |
|  | 4 | **Ceiling Finihsing** |  | 2013-02-17 | 2013-03-25 |  |  |  |  |  |  |  |
| 1.4.3.3.1.1.160 |  | Install gypsum board ceiling system | 25d | 2013-02-17 | 2013-03-12 | 1.4.3.3.1.1.100, 1.4.3.3.1.1.080 |  | -109.25d | 0d | SSH-Construction Manhours [361.97 h] | 5,400 |  |
| 1.4.3.3.1.1.170 |  | Install painting work | 25d | 2013-02-24 | 2013-03-19 | 1.4.3.3.1.1.160 SS+7d |  | -109.25d | 0d | SSH-Construction Manhours [289.99 h] | 4,200 |  |
| 1.4.3.3.1.1.180 |  | Install roof water proofing system & scrupper | 25d | 2013-03-03 | 2013-03-25 | 1.4.3.3.1.1.170 SS+7d |  | -93d | 21d | SSH-Construction Manhours [289.99 h] | 30,000 | 0.0088619018 |
|  | 5 | **Doors / Windows / Toilet Accs** |  | 2013-03-12 | 2013-04-14 |  |  |  |  |  |  |  |
| 1.4.3.3.1.1.190 |  | Install doors & windows | 25d | 2013-03-12 | 2013-04-04 | 1.4.3.3.1.1.290 |  | -114d | 0d | SSH-Construction Manhours [231.99 h] | 18,000 |  |
| 1.4.3.3.1.1.200 |  | Install toilet fixtures & accs | 25d | 2013-03-17 | 2013-04-09 | 1.4.3.3.1.1.190 SS+5d |  | -114d | 0d | SSH-Construction Manhours [231.99 h] | 180,000 |  |
| 1.4.3.3.1.1.210 |  | Install cabinet & counter top | 25d | 2013-03-21 | 2013-04-14 | 1.4.3.3.1.1.200 SS+5d, 1.4.3.3.1.1.180 SS |  | -114d | 86.42d | SSH-Construction Manhours [231.99 h] | 165,000 | 0.04874046 |
|  | 4 | **Electrical works** |  | 2013-01-17 | 2013-02-24 |  |  |  |  |  |  |  |
| 1.4.3.3.1.1.220 |  | Install electric conduits / fittings | 25d | 2013-01-17 | 2013-02-10 | 1.4.3.3.1.1.090 SS |  | -86d | 0d | SSH-Construction Manhours [139.76 h] | 18,190 |  |
| 1.4.3.3.1.1.230 |  | Install cables / wires | 25d | 2013-01-20 | 2013-02-12 | 1.4.3.3.1.1.220 SS+3d |  | -86d | 0d | SSH-Construction Manhours [139.76 h] | 125,000 |  |
| 1.4.3.3.1.1.240 |  | Install lighting fixtures | 25d | 2013-01-23 | 2013-02-16 | 1.4.3.3.1.1.230 SS+3d |  | -86d | 0d | SSH-Construction Manhours [139.76 h] | 35,000 |  |
| 1.4.3.3.1.1.250 |  | Install panelboards | 25d | 2013-01-26 | 2013-02-18 | 1.4.3.3.1.1.240 SS+3d |  | -86d | 0d | SSH-Construction Manhours [144.65 h] | 5,000 |  |
| 1.4.3.3.1.1.255 |  | Install Lighting control panel | 25d | 2013-01-28 | 2013-02-20 | 1.4.3.3.1.1.250 SS+2d |  | -86d | 0d | SSH-Construction Manhours [144.65 h] | 5,250 | 0.0015508328 |
| 1.4.3.3.1.1.260 |  | Install disconnect switches | 25d | 2013-01-29 | 2013-02-21 | 1.4.3.3.1.1.250 SS+2d, 1.4.3.3.1.1.255 SS+2d |  | -86d | 0d | SSH-Construction Manhours [144.65 h] | 350 |  |
| 1.4.3.3.1.1.270 |  | Install grounding system | 25d | 2013-01-31 | 2013-02-24 | 1.4.3.3.1.1.260 SS+2d |  | -86d | 18d | SSH-Construction Manhours [144.65 h] | 7,500 |  |
|  | 5 | **Water Supply System** |  | 2013-02-10 | 2013-03-05 |  |  |  |  |  |  |  |
| 1.4.3.3.1.1.280 |  | Install water supply system | 25d | 2013-02-10 | 2013-03-05 | 1.4.3.3.1.1.090 |  | -114d | 0d | SSH-Construction Manhours [217.32 h] | 30,000 | 0.0088619018 |
|  | 6 | **Sewer System** |  | 2013-02-17 | 2013-03-12 |  |  |  |  |  |  |  |
| 1.4.3.3.1.1.290 |  | Install sewer system | 25d | 2013-02-17 | 2013-03-12 | 1.4.3.3.1.1.280 SS+8d |  | -114d | 0d | SSH-Construction Manhours [217.32 h] | 35,000 | 0.0103388854 |
|  | 7 | **HVAC System** |  | 2013-03-12 | 2013-04-04 |  |  |  |  |  |  |  |
| 1.4.3.3.1.1.300 |  | Install HVAC system | 25d | 2013-03-12 | 2013-04-04 | 1.4.3.3.1.1.290, 1.4.3.3.1.1.270 |  | -104d | 96.42d | SSH-Construction Manhours [289.99 h] | 30,000 | 0.0088619018 |
|  | 8 | **Toilet # 2** |  | 2012-06-03 | 2013-05-07 |  |  |  |  |  |  |  |
|  | 1 | **Civil works** |  | 2012-06-03 | 2013-02-16 |  |  |  |  |  |  |  |
| 1.4.3.3.1.2.010 |  | Excavation leveling & compaction for toilet # 2 bldg fdns | 10d | 2012-06-03 A | 2012-06-12 A | 1.4.3.3.1.1.010 | 100% |  |  | SSH-Construction Manhours [542.95 h]; Excavator [80 h]; Dump Truck [80 h] | 1,250 |  |
| 1.4.3.3.1.2.020 |  | Backfilling/compation | 12.5d | 2013-02-04 | 2013-02-16 | 1.4.3.3.1.2.070 |  | -77.25d | 61.5d | SSH-Construction Manhours [325.63 h]; Dump Truck [100 h]; Compactor [100 h] | 1,225 | 0.000361861 |

| ID | WBS | Activity | Duration | Start | Finish | Predecessors | Complete | Remaining | Planned start | Planned finish | Total float | Free float | Resources | Cost | QTY |
| --- | --- | --- | --- | --- | --- | --- | --- | --- | --- | --- | --- | --- | --- | --- | --- |
|  | 2 | **Structural works** |  | 2012-06-03 | 2013-03-05 |  |  |  |  |  |  |  |  |  |  |
| 1.4.3.3.1.2.030 |  | Install lean concrete for reinforced fdns for toilet bldg | 18.75d | 2012-06-03 A | 2012-06-20 A | 1.4.3.3.1.2.010 SS | 100% |  |  |  |  |  | SSH-Construction Manhours [434.64 h] | 1,050 |  |
| 1.4.3.3.1.2.040 |  | Install reinforced fdns for toilet bldg | 31.25d | 2012-06-17 A | 2012-07-16 A | 1.4.3.3.1.2.030 SS+15d | 100% |  |  |  |  |  | SSH-Construction Manhours [633.79 h] | 28,600 |  |
| 1.4.3.3.1.2.050 |  | Install reinforced columns | 45d | 2012-07-01 A | 2012-08-12 A | 1.4.3.3.1.2.040 SS+15d | 100% |  |  |  |  |  | SSH-Construction Manhours [768.66 h] | 18,000 |  |
| 1.4.3.3.1.2.060 |  | Install reinforced roof beams | 50d | 2012-12-02 | 2013-01-17 | 1.4.3.3.1.2.050 SS+15d |  |  |  |  | -138.75d | 0d | SSH-Construction Manhours [768.66 h] | 18,000 |  |
| 1.4.3.3.1.2.070 |  | Install reinforced roof slab /paraphet | 37.5d | 2012-12-31 | 2013-02-04 | 1.4.3.3.1.2.060 SS+31.25d |  |  |  |  | -138.75d | 0d | SSH-Construction Manhours [768.66 h] | 26,000 |  |
| 1.4.3.3.1.2.080 |  | Install reinforced slab on grade | 37.5d | 2013-01-29 | 2013-03-05 | 1.4.3.3.1.2.070 SS+31.25d |  |  |  |  | -106d | 32.75d | SSH-Construction Manhours [462.59 h] | 14,720 | 0.0043482398 |
|  | 3 | **Architectural works** |  | 2012-09-17 | 2013-05-07 |  |  |  |  |  |  |  |  |  |  |
|  | 1 | **Masonry** |  | 2012-09-17 | 2013-02-27 |  |  |  |  |  |  |  |  |  |  |
| 1.4.3.3.1.2.090 |  | Install 200mm thk CMU blocks | 25d | 2012-09-17 A | 2013-02-23 | 1.4.3.3.1.2.070 | 20% | 20d | 2012-09-17 | 2012-10-10 | -138.75d | 0d | SSH-Construction Manhours [579.99 h] | 14,915 |  |
| 1.4.3.3.1.2.100 |  | Install 50 mm thk mortar plastering work | 25d | 2013-02-04 | 2013-02-27 | 1.4.3.3.1.2.090 SS+10d |  |  |  |  | -138.75d | 0d | SSH-Construction Manhours [436.74 h] | 37,100 | 0.0109592186 |
|  | 2 | **Floor Finishing** |  | 2013-04-04 | 2013-05-07 |  |  |  |  |  |  |  |  |  |  |
| 1.4.3.3.1.2.110 |  | Install cement toping work | 25d | 2013-04-04 | 2013-04-28 | 1.4.3.3.1.2.140 SS, 1.4.3.3.1.2.080 |  |  |  |  | -138.75d | 0d | SSH-Construction Manhours [434.64 h] | 5,500 |  |
| 1.4.3.3.1.2.120 |  | Install cermaic tiling work | 25d | 2013-04-14 | 2013-05-07 | 1.4.3.3.1.2.110 SS+10d, 1.4.3.3.1.2.020, 1.4.3.3.1.2.150 SS |  |  |  |  | -138.75d | 61.67d | SSH-Construction Manhours [434.64 h] | 11,000 | 0.003249364 |
|  | 3 | **Wall Finishing** |  | 2013-03-30 | 2013-05-05 |  |  |  |  |  |  |  |  |  |  |
| 1.4.3.3.1.2.130 |  | Install phenolic toilet partition | 25d | 2013-03-30 | 2013-04-21 | 1.4.3.3.1.2.170 |  |  |  |  | -138.75d | 0d | SSH-Construction Manhours [347.29 h] | 70,000 |  |
| 1.4.3.3.1.2.140 |  | Install ceramic tiling work | 25d | 2013-04-04 | 2013-04-28 | 1.4.3.3.1.2.130 SS+7d |  |  |  |  | -138.75d | 0d | SSH-Construction Manhours [347.29 h] | 25,000 |  |
| 1.4.3.3.1.2.150 |  | Install textured painted work on CMU wall | 25d | 2013-04-11 | 2013-05-05 | 1.4.3.3.1.2.140 SS+7d |  |  |  |  | -135.75d | 3d | SSH-Construction Manhours [347.29 h] | 33,750 | 0.0099696395 |
|  | 4 | **Ceiling Finihsing** |  | 2013-02-27 | 2013-04-04 |  |  |  |  |  |  |  |  |  |  |
| 1.4.3.3.1.2.160 |  | Install gypsum board ceiling system | 25d | 2013-02-27 | 2013-03-23 | 1.4.3.3.1.2.100 |  |  |  |  | -138.75d | 0d | SSH-Construction Manhours [347.29 h] | 5,400 |  |
| 1.4.3.3.1.2.170 |  | Install painting work | 25d | 2013-03-06 | 2013-03-28 | 1.4.3.3.1.2.160 SS+7d |  |  |  |  | -138.75d | 0d | SSH-Construction Manhours [347.29 h] | 4,200 |  |
| 1.4.3.3.1.2.180 |  | Install roof water proofing system & scrupper | 25d | 2013-03-12 | 2013-04-04 | 1.4.3.3.1.2.170 SS+7d |  |  |  |  | -103.75d | 96.67d | SSH-Construction Manhours [347.29 h] | 30,000 | 0.0088619018 |
|  | 5 | **Doors / Windows / Toilet Accs** |  | 2013-03-25 | 2013-04-27 |  |  |  |  |  |  |  |  |  |  |
| 1.4.3.3.1.2.190 |  | Install doors & windows | 25d | 2013-03-25 | 2013-04-17 | 1.4.3.3.1.2.290 |  |  |  |  | -127.75d | 0d | SSH-Construction Manhours [144.65 h] | 18,000 |  |
| 1.4.3.3.1.2.200 |  | Install toilet fixtures & accs | 25d | 2013-03-30 | 2013-04-22 | 1.4.3.3.1.2.190 SS+5d |  |  |  |  | -127.75d | 0d | SSH-Construction Manhours [144.65 h] | 180,000 |  |
| 1.4.3.3.1.2.210 |  | Install cabinet & counter top | 25d | 2013-04-03 | 2013-04-27 | 1.4.3.3.1.2.200 SS+5d |  |  |  |  | -127.75d | 72.67d | SSH-Construction Manhours [144.65 h] | 165,000 | 0.04874046 |

| ID | WBS | Activity | Duration | Start | Finish | Predecessors | Complete | Total float | Free float | Resources | Cost | QTY |
| --- | --- | --- | --- | --- | --- | --- | --- | --- | --- | --- | --- | --- |
|  | 4 | **Electrical works** |  | 2013-02-04 | 2013-03-13 |  |  |  |  |  |  |  |
| 1.4.3.3.1.2.220 |  | Install electric conduits / fittings | 25d | 2013-02-04 | 2013-02-27 | 1.4.3.3.1.2.090 SS |  | -104.75d | 0d | SSH-Construction Manhours [144.65 h] | 18,190 |  |
| 1.4.3.3.1.2.230 |  | Install cables / wires | 25d | 2013-02-06 | 2013-03-02 | 1.4.3.3.1.2.220 SS+3d |  | -104.75d | 0d | SSH-Construction Manhours [144.65 h] | 125,000 |  |
| 1.4.3.3.1.2.240 |  | Install lighting fixtures | 25d | 2013-02-10 | 2013-03-05 | 1.4.3.3.1.2.230 SS+3d |  | -104.75d | 0d | SSH-Construction Manhours [144.65 h] | 35,000 |  |
| 1.4.3.3.1.2.250 |  | Install panelboards | 25d | 2013-02-12 | 2013-03-07 | 1.4.3.3.1.2.240 SS+3d |  | -104.75d | 0d | SSH-Construction Manhours [144.65 h] | 5,000 |  |
| 1.4.3.3.1.2.255 |  | Install lighting control panel | 25d | 2013-02-14 | 2013-03-10 | 1.4.3.3.1.2.250 SS+2d |  | -104.75d | 0d | SSH-Construction Manhours [144.65 h] | 5,250 | 0.0015508328 |
| 1.4.3.3.1.2.260 |  | Install disconnect switches | 25d | 2013-02-16 | 2013-03-11 | 1.4.3.3.1.2.250 SS+2d, 1.4.3.3.1.2.255 SS+2d |  | -104.75d | 0d | SSH-Construction Manhours [144.65 h] | 350 |  |
| 1.4.3.3.1.2.270 |  | Install grounding system | 25d | 2013-02-18 | 2013-03-13 | 1.4.3.3.1.2.260 SS+2d |  | -104.75d | 13d | SSH-Construction Manhours [144.65 h] | 7,500 |  |
|  | 5 | **Water Supply System** |  | 2013-02-23 | 2013-03-18 |  |  |  |  |  |  |  |
| 1.4.3.3.1.2.280 |  | Install water supply system | 25d | 2013-02-23 | 2013-03-18 | 1.4.3.3.1.2.090 |  | -127.75d | 0d | SSH-Construction Manhours [173.3 h] | 30,000 | 0.0088619018 |
|  | 6 | **Sewer System** |  | 2013-03-02 | 2013-03-25 |  |  |  |  |  |  |  |
| 1.4.3.3.1.2.290 |  | Install sewer system | 25d | 2013-03-02 | 2013-03-25 | 1.4.3.3.1.2.280 SS+8d |  | -127.75d | 0d | SSH-Construction Manhours [173.3 h] | 35,000 | 0.0103388854 |
|  | 7 | **HVAC System** |  | 2013-03-25 | 2013-04-17 |  |  |  |  |  |  |  |
| 1.4.3.3.1.2.300 |  | Install HVAC system | 25d | 2013-03-25 | 2013-04-17 | 1.4.3.3.1.2.290, 1.4.3.3.1.2.270 |  | -117.75d | 82.67d | SSH-Construction Manhours [116 h] | 30,000 | 0.0088619018 |
|  | 2 | **Toilet # 3** |  | 2012-06-12 | 2013-04-21 |  |  |  |  |  |  |  |
|  | 1 | **Civil works** |  | 2012-06-12 | 2013-01-20 |  |  |  |  |  |  |  |
| 1.4.3.3.1.3.010 |  | Excavation leveling & compaction for toilet # 3 bldg fdns | 10d | 2012-06-12 A | 2012-06-21 A | 1.4.3.3.1.2.010 | 100% |  |  | SSH-Construction Manhours [174.69 h]; Excavator [80 h]; Dump Truck [80 h] | 1,250 |  |
| 1.4.3.3.1.3.020 |  | Backfilling/compation | 12.5d | 2013-01-08 | 2013-01-20 | 1.4.3.3.1.3.070 |  | -48.5d | 70d | SSH-Construction Manhours [144.65 h]; Dump Truck [100 h]; Compactor [100 h] | 1,225 | 0.000361861 |
|  | 2 | **Structural works** |  | 2012-06-18 | 2013-02-10 |  |  |  |  |  |  |  |
| 1.4.3.3.1.3.030 |  | Install lean concrete for reinforced fdns for toilet bldg | 18.75d | 2012-06-18 A | 2012-07-05 A | 1.4.3.3.1.3.010 SS+6d | 100% |  |  | SSH-Construction Manhours [272.52 h] | 1,050 |  |
| 1.4.3.3.1.3.040 |  | Install reinforced fdns for toilet bldg | 31.25d | 2012-07-02 A | 2012-07-31 A | 1.4.3.3.1.3.030 SS+15d | 100% |  |  | SSH-Construction Manhours [633.79 h] | 28,600 |  |
| 1.4.3.3.1.3.050 |  | Install reinforced columns | 37.5d | 2012-07-16 A | 2012-08-20 A | 1.4.3.3.1.3.040 SS+15d | 100% |  |  | SSH-Construction Manhours [768.66 h] | 18,000 |  |
| 1.4.3.3.1.3.060 |  | Install reinforced roof beams | 37.5d | 2012-12-02 | 2013-01-06 | 1.4.3.3.1.3.050 SS+15d |  | -121.25d | 0d | SSH-Construction Manhours [768.66 h] | 18,000 |  |
| 1.4.3.3.1.3.070 |  | Install reinforced roof slab /paraphet | 20d | 2012-12-20 | 2013-01-08 | 1.4.3.3.1.3.060 SS+20d |  | -121.25d | 0d | SSH-Construction Manhours [768.66 h] | 26,000 |  |
| 1.4.3.3.1.3.080 |  | Install reinforced slab on grade | 40d | 2013-01-03 | 2013-02-10 | 1.4.3.3.1.3.070 SS+15d |  | -71d | 47.5d | SSH-Construction Manhours [649.86 h] | 14,720 | 0.0043482398 |

| ID | WBS | Activity | Duration | Start | Finish | Predecessors | Complete | Remaining | Planned start | Planned finish | Total float | Free float | Resources | Cost | QTY |
| --- | --- | --- | --- | --- | --- | --- | --- | --- | --- | --- | --- | --- | --- | --- | --- |
|  | 3 | **Architectural works** |  | 2012-09-01 | 2013-04-21 |  |  |  |  |  |  |  |  |  |  |
|  | 1 | **Masonry** |  | 2012-09-01 | 2013-02-16 |  |  |  |  |  |  |  |  |  |  |
| 1.4.3.3.1.3.090 |  | Install 200mm thk CMU blocks | 25d | 2012-09-01 A | 2013-01-27 | 1.4.3.3.1.3.070 FF+20d | 85% | 3.75d | 2012-09-01 | 2012-09-24 | -121.25d | 0d | SSH-Construction Manhours [462.59 h] | 14,915 |  |
| 1.4.3.3.1.3.100 |  | Install 50 mm thk mortar plastering work | 25d | 2012-09-10 A | 2013-02-16 | 1.4.3.3.1.3.090 SS+10d |  | 25d | 2012-09-10 | 2012-10-03 | -121.25d | 0d | SSH-Construction Manhours [347.29 h] | 37,100 | 0.0109592186 |
|  | 2 | **Floor Finishing** |  | 2013-03-24 | 2013-04-18 |  |  |  |  |  |  |  |  |  |  |
| 1.4.3.3.1.3.110 |  | Install cement toping work | 25d | 2013-03-24 | 2013-04-15 | 1.4.3.3.1.3.140 FF |  |  |  |  | -118.5d | 0d | SSH-Construction Manhours [1086.6 h] | 5,500 |  |
| 1.4.3.3.1.3.120 |  | Install ceramic tiling work | 25d | 2013-03-26 | 2013-04-18 | 1.4.3.3.1.3.110 SS+3d, 1.4.3.3.1.3.020, 1.4.3.3.1.3.080 |  |  |  |  | -118.5d | 81.92d | SSH-Construction Manhours [1086.6 h] | 11,000 | 0.003249364 |
|  | 3 | **Wall Finishing** |  | 2013-03-17 | 2013-04-21 |  |  |  |  |  |  |  |  |  |  |
| 1.4.3.3.1.3.130 |  | Install phenolic toilet partition | 25d | 2013-03-17 | 2013-04-09 | 1.4.3.3.1.3.170 |  |  |  |  | -121.25d | 0d | SSH-Construction Manhours [1085.9 h] | 70,000 |  |
| 1.4.3.3.1.3.140 |  | Install ceramic tiling work | 25d | 2013-03-24 | 2013-04-15 | 1.4.3.3.1.3.130 SS+7d |  |  |  |  | -121.25d | 0d | SSH-Construction Manhours [1085.9 h] | 25,000 |  |
| 1.4.3.3.1.3.150 |  | Install textured painted work on CMU wall | 23.75d | 2013-03-30 | 2013-04-21 | 1.4.3.3.1.3.140 SS+7d |  |  |  |  | -121.25d | 79.17d | SSH-Construction Manhours [1011.13 h] | 33,750 | 0.0099696395 |
|  | 4 | **Ceiling Finihsing** |  | 2012-10-03 | 2013-03-23 |  |  |  |  |  |  |  |  |  |  |
| 1.4.3.3.1.3.160 |  | Install gypsum board ceiling system | 25d | 2012-10-03 A | 2013-03-10 | 1.4.3.3.1.3.100 | 3% | 24.25d | 2012-10-03 | 2012-10-27 | -121.25d | 0d | SSH-Construction Manhours [434.64 h] | 5,400 |  |
| 1.4.3.3.1.3.170 |  | Install painting work | 25d | 2013-02-21 | 2013-03-17 | 1.4.3.3.1.3.160 SS+7d |  |  |  |  | -121.25d | 0d | SSH-Construction Manhours [361.97 h] | 4,200 |  |
| 1.4.3.3.1.3.180 |  | Install roof water proofing system & scrupper | 25d | 2013-02-28 | 2013-03-23 | 1.4.3.3.1.3.170 SS+7d |  |  |  |  | -90.5d | 109.92d | SSH-Construction Manhours [361.97 h] | 30,000 | 0.0088619018 |
|  | 5 | **Doors / Windows / Toilet Accs** |  | 2013-02-20 | 2013-03-25 |  |  |  |  |  |  |  |  |  |  |
| 1.4.3.3.1.3.190 |  | Install doors & windows | 25d | 2013-02-20 | 2013-03-16 | 1.4.3.3.1.3.290, 1.4.3.3.1.3.270 |  |  |  |  | -92.75d | 0d | SSH-Construction Manhours [361.97 h] | 18,000 |  |
| 1.4.3.3.1.3.200 |  | Install toilet fixtures & accs | 25d | 2013-02-27 | 2013-03-23 | 1.4.3.3.1.3.190 SS+7.5d |  |  |  |  | -92.75d | 0d | SSH-Construction Manhours [579.29 h] | 180,000 |  |
| 1.4.3.3.1.3.210 |  | Install cabinet & counter top | 25d | 2013-03-02 | 2013-03-25 | 1.4.3.3.1.3.200 SS+3d |  |  |  |  | -92.75d | 107.67d | SSH-Construction Manhours [579.29 h] | 165,000 | 0.04874046 |
|  | 4 | **Electrical works** |  | 2013-01-23 | 2013-02-20 |  |  |  |  |  |  |  |  |  |  |
| 1.4.3.3.1.3.220 |  | Install electric conduits / fittings | 15d | 2013-01-23 | 2013-02-06 | 1.4.3.3.1.3.090 SS |  |  |  |  | -92.75d | 0d | SSH-Construction Manhours [138.36 h] | 18,190 |  |
| 1.4.3.3.1.3.230 |  | Install cables / wires | 15d | 2013-01-26 | 2013-02-09 | 1.4.3.3.1.3.220 SS+3d |  |  |  |  | -92.75d | 0d | SSH-Construction Manhours [208.24 h] | 125,000 |  |
| 1.4.3.3.1.3.240 |  | Install lighting fixtures | 15d | 2013-01-29 | 2013-02-12 | 1.4.3.3.1.3.230 SS+3d |  |  |  |  | -92.75d | 0d | SSH-Construction Manhours [208.24 h] | 35,000 |  |
| 1.4.3.3.1.3.250 |  | Install panelboards | 15d | 2013-01-31 | 2013-02-14 | 1.4.3.3.1.3.240 SS+3d |  |  |  |  | -92.75d | 0d | SSH-Construction Manhours [87.35 h] | 5,000 |  |
| 1.4.3.3.1.3.255 |  | Install lighting control panel | 15d | 2013-02-03 | 2013-02-17 | 1.4.3.3.1.3.250 SS+2d |  |  |  |  | -92.75d | 0d | SSH-Construction Manhours [87.35 h] | 5,250 | 0.0015508328 |
| 1.4.3.3.1.3.260 |  | Install disconnect switches | 15d | 2013-02-04 | 2013-02-18 | 1.4.3.3.1.3.250 SS+2d, 1.4.3.3.1.3.255 SS+2d |  |  |  |  | -92.75d | 0d | SSH-Construction Manhours [87.35 h] | 350 |  |
| 1.4.3.3.1.3.270 |  | Install grounding system | 15d | 2013-02-06 | 2013-02-20 | 1.4.3.3.1.3.260 SS+2d |  |  |  |  | -92.75d | 0d | SSH-Construction Manhours [87.35 h] | 7,500 |  |

| ID | WBS | Activity | Duration | Start | Finish | Predecessors | Complete | Remaining | Planned start | Planned finish | Total float | Free float | Resources | Cost | QTY |
| --- | --- | --- | --- | --- | --- | --- | --- | --- | --- | --- | --- | --- | --- | --- | --- |
|  | 5 | **Water Supply System** |  | 2013-01-27 | 2013-02-10 |  |  |  |  |  |  |  |  |  |  |
| 1.4.3.3.1.3.280 |  | Install water supply system | 15d | 2013-01-27 | 2013-02-10 | 1.4.3.3.1.3.090 |  |  |  |  | -89.5d | 0d | SSH-Construction Manhours [132.77 h] | 30,000 | 0.0088619018 |
|  | 6 | **Sewer System** |  | 2013-02-03 | 2013-02-17 |  |  |  |  |  |  |  |  |  |  |
| 1.4.3.3.1.3.290 |  | Install sewer system | 15d | 2013-02-03 | 2013-02-17 | 1.4.3.3.1.3.280 SS+8d |  |  |  |  | -89.5d | 0d | SSH-Construction Manhours [132.77 h] | 35,000 | 0.0103388854 |
|  | 7 | **HVAC System** |  | 2013-02-17 | 2013-03-03 |  |  |  |  |  |  |  |  |  |  |
| 1.4.3.3.1.3.300 |  | Install HVAC system | 15d | 2013-02-17 | 2013-03-03 | 1.4.3.3.1.3.290 |  |  |  |  | -69d | 131.42d | SSH-Construction Manhours [349.39 h] | 30,000 | 0.0088619018 |
|  | 4 | **Snack Booths (4 nos)** |  | 2012-07-15 | 2013-04-06 |  |  |  |  |  |  |  |  |  |  |
|  | 1 | **Snack Booth # 1** |  | 2012-07-15 | 2013-03-14 |  |  |  |  |  |  |  |  |  |  |
|  | 1 | **Civil work** |  | 2012-07-15 | 2013-01-26 |  |  |  |  |  |  |  |  |  |  |
| 1.4.3.4.1.010 |  | Excavation leveling & compaction for snack booth #1 | 10d | 2012-07-15 A | 2012-07-24 A | 1.4.3.3.1.1.010 FS+45d | 100% |  |  |  |  |  | SSH-Construction Manhours [186.23 h]; Excavator [80 h]; Dump Truck [80 h] | 475 |  |
| 1.4.3.4.1.015 |  | Backfill/comp for snack booth #1 | 12.5d | 2013-01-14 | 2013-01-26 | 1.4.3.4.1.050 |  |  |  |  | -97.5d | 7.25d | SSH-Construction Manhours [97.16 h]; Compactor [100 h]; Dump Truck [100 h] | 313 | 9.24592E-005 |
|  | 2 | **Structural work** |  | 2012-07-21 | 2013-01-14 |  |  |  |  |  |  |  |  |  |  |
| 1.4.3.4.1.020 |  | Install lean concrete for reinforced fdns for snack both 1 | 18.75d | 2012-07-21 A | 2012-12-05 | 1.4.3.4.1.010 SS+6d | 80% | 3.75d | 2012-07-21 | 2012-08-07 | -104.75d | 0d | SSH-Construction Manhours [242.9 h] | 446 |  |
| 1.4.3.4.1.030 |  | Install reinforced fdns for snack booth1 | 31.25d | 2012-07-30 A | 2012-12-29 | 1.4.3.4.1.020 SS+10d | 7% | 28.91d | 2012-07-30 | 2012-08-28 | -104.75d | 0d | SSH-Construction Manhours [1157.84 h] | 4,650 |  |
| 1.4.3.4.1.040 |  | Install reinforced roof slab/paraphet snack booth1 | 31.25d | 2012-12-02 | 2012-12-31 | 1.4.3.4.1.030 SS+15d |  |  |  |  | -104.75d | 0d | SSH-Construction Manhours [348.16 h] | 4,650 |  |
| 1.4.3.4.1.050 |  | Install reinforced slab on grade | 31.25d | 2012-12-16 | 2013-01-14 | 1.4.3.4.1.040 SS+15d |  |  |  |  | -104.75d | 0d | SSH-Construction Manhours [348.16 h] | 3,760 | 0.0011106917 |
|  | 3 | **Architectural work** |  | 2012-12-30 | 2013-03-14 |  |  |  |  |  |  |  |  |  |  |
| 1.4.3.4.1.060 |  | Install masonry work for snack booth1 | 18.75d | 2012-12-30 | 2013-01-16 | 1.4.3.4.1.050 SS+15d |  |  |  |  | -104.75d | 0d | SSH-Construction Manhours [139.27 h] | 4,655 |  |
| 1.4.3.4.1.070 |  | Install plastering work | 18.75d | 2013-01-05 | 2013-01-22 | 1.4.3.4.1.060 SS+6d |  |  |  |  | -104.75d | 0d | SSH-Construction Manhours [69.63 h] | 4,912 |  |
| 1.4.3.4.1.080 |  | Install roof proofing system | 18.75d | 2013-01-09 | 2013-01-27 | 1.4.3.4.1.070 SS+5d |  |  |  |  | -104.75d | 0d | SSH-Construction Manhours [69.63 h] | 7,500 |  |
| 1.4.3.4.1.090 |  | Install ceiling system | 18.75d | 2013-01-14 | 2013-01-31 | 1.4.3.4.1.080 SS+5d |  |  |  |  | -104.75d | 0d | SSH-Construction Manhours [69.63 h] | 525 |  |
| 1.4.3.4.1.100 |  | Install concret toping, ceramic floor finishes | 18.75d | 2013-01-19 | 2013-02-05 | 1.4.3.4.1.090 SS+5d |  |  |  |  | -104.75d | 0d | SSH-Construction Manhours [210.52 h] | 1,575 |  |
| 1.4.3.4.1.110 |  | Install painting work | 18.75d | 2013-01-23 | 2013-02-10 | 1.4.3.4.1.100 SS+5d |  |  |  |  | -104.75d | 0d | SSH-Construction Manhours [210.52 h] | 5,438 |  |
| 1.4.3.4.1.120 |  | Install plumbing fixture | 18.75d | 2013-01-28 | 2013-02-14 | 1.4.3.4.1.110 SS+5d |  |  |  |  | -104.75d | 0d | SSH-Construction Manhours [210.52 h] | 4,501 |  |
| 1.4.3.4.1.130 |  | Install doors | 18.75d | 2013-02-02 | 2013-02-19 | 1.4.3.4.1.120 SS+5d, 1.4.3.4.1.015 |  |  |  |  | -104.75d | 0d | SSH-Construction Manhours [72.87 h] | 4,650 |  |
| 1.4.3.4.1.140 |  | Install windows | 18.75d | 2013-02-07 | 2013-02-25 | 1.4.3.4.1.130 SS+6.25d |  |  |  |  | -104.75d | 0d | SSH-Construction Manhours [72.87 h] | 3,515 |  |
| 1.4.3.4.1.150 |  | Install furniture & kitchen counter top | 18.75d | 2013-02-13 | 2013-03-03 | 1.4.3.4.1.140 SS+6.25d |  |  |  |  | -104.75d | 0d | SSH-Construction Manhours [72.87 h] | 15,000 |  |
| 1.4.3.4.1.160 |  | Install kitchen & dinnning equipments | 18.75d | 2013-02-19 | 2013-03-09 | 1.4.3.4.1.150 SS+6.25d |  |  |  |  | -104.75d | 0d | SSH-Construction Manhours [72.87 h] | 30,000 |  |
| 1.4.3.4.1.170 |  | Install wooden trellis | 18.75d | 2013-02-25 | 2013-03-14 | 1.4.3.4.1.160 SS+6.25d, 1.4.3.4.1.330 FF |  |  |  |  | -104.75d | 0d | SSH-Construction Manhours [72.87 h] | 3,600 | 0.0010634282 |

| ID | WBS | Activity | Duration | Start | Finish | Predecessors | Complete | Total float | Free float | Resources | Cost | QTY |
| --- | --- | --- | --- | --- | --- | --- | --- | --- | --- | --- | --- | --- |
|  | 4 | **Electrical work** |  | 2013-01-27 | 2013-03-02 |  |  |  |  |  |  |  |
| 1.4.3.4.1.180 |  | Install electric conduits | 18.75d | 2013-01-27 | 2013-02-13 | 1.4.3.4.1.080 |  | -104d | 0d | SSH-Construction Manhours [72.87 h] | 1,875 |  |
| 1.4.3.4.1.190 |  | Install cables & wires | 18.75d | 2013-02-02 | 2013-02-18 | 1.4.3.4.1.180 SS+6d |  | -104d | 0d | SSH-Construction Manhours [72.87 h] | 350 |  |
| 1.4.3.4.1.200 |  | Install lighting fixtures | 18.75d | 2013-02-05 | 2013-02-23 | 1.4.3.4.1.190 SS+4d |  | -104d | 0d | SSH-Construction Manhours [72.87 h] | 4,500 |  |
| 1.4.3.4.1.210 |  | Install panelboards | 18.75d | 2013-02-07 | 2013-02-25 | 1.4.3.4.1.200 SS+3d |  | -104d | 0d | SSH-Construction Manhours [72.87 h] | 4,000 |  |
| 1.4.3.4.1.220 |  | Install grounding system | 18.75d | 2013-02-10 | 2013-02-27 | 1.4.3.4.1.210 SS+2d |  | -104d | 0d | SSH-Construction Manhours [72.87 h] | 1,000 |  |
| 1.4.3.4.1.230 |  | Testing & commissioing of electric system | 18.75d | 2013-02-12 | 2013-03-02 | 1.4.3.4.1.220 SS+3d |  | -104d | 0d | SSH-Construction Manhours [72.87 h] | 1,000 | 0.0002953967 |
|  | 5 | **Communciation work** |  | 2013-01-27 | 2013-03-13 |  |  |  |  |  |  |  |
| 1.4.3.4.1.240 |  | Install comm condutis & fittings | 12.5d | 2013-01-27 | 2013-02-07 | 1.4.3.4.1.180 SS |  | -96.25d | 0d | SSH-Construction Manhours [48.58 h] | 750 |  |
| 1.4.3.4.1.250 |  | Install UTP cable | 12.5d | 2013-01-30 | 2013-02-11 | 1.4.3.4.1.240 SS+4d |  | -93.25d | 0d | SSH-Construction Manhours [89.06 h] | 420 |  |
| 1.4.3.4.1.260 |  | Install equipment cabinet | 12.5d | 2013-02-03 | 2013-02-14 | 1.4.3.4.1.250 SS+4d |  | -93.25d | 0d | SSH-Construction Manhours [64.77 h] | 2,600 |  |
| 1.4.3.4.1.270 |  | Install data network switch | 12.5d | 2013-02-05 | 2013-02-17 | 1.4.3.4.1.260 SS+2d |  | -93.25d | 0d | SSH-Construction Manhours [64.77 h] | 40,000 |  |
| 1.4.3.4.1.280 |  | Install copper splice closure | 12.5d | 2013-02-06 | 2013-02-18 | 1.4.3.4.1.270 SS+2d |  | -93.25d | 0d | SSH-Construction Manhours [64.77 h] | 10,000 |  |
| 1.4.3.4.1.290 |  | Install patch panel | 12.5d | 2013-02-09 | 2013-02-20 | 1.4.3.4.1.280 SS+2d |  | -93.25d | 0d | SSH-Construction Manhours [64.77 h] | 8,000 |  |
| 1.4.3.4.1.300 |  | Install fiber patch panel | 12.5d | 2013-02-11 | 2013-02-23 | 1.4.3.4.1.290 SS+3d |  | -93.25d | 0d | SSH-Construction Manhours [64.77 h] | 7,000 |  |
| 1.4.3.4.1.310 |  | Install patch cord | 12.5d | 2013-02-14 | 2013-02-26 | 1.4.3.4.1.300 SS+3d |  | -93.25d | 0d | SSH-Construction Manhours [64.77 h] | 5,040 |  |
| 1.4.3.4.1.320 |  | Install rack manager | 12.5d | 2013-02-17 | 2013-02-28 | 1.4.3.4.1.310 SS+3d |  | -93.25d | 10.75d | SSH-Construction Manhours [64.77 h] | 2,300 |  |
| 1.4.3.4.1.330 |  | Testing & commissioning of comm system | 12.5d | 2013-03-02 | 2013-03-13 | 1.4.3.4.1.320 SS+3d, 1.4.3.4.1.230, 1.4.3.4.1.360 |  | -104d | 0.75d | SSH-Construction Manhours [64.77 h] | 2,500 | 0.0007384918 |
|  | 6 | **Mechanical work** |  | 2013-01-27 | 2013-02-23 |  |  |  |  |  |  |  |
| 1.4.3.4.1.340 |  | Install water supply system | 15d | 2013-01-27 | 2013-02-10 | 1.4.3.4.1.240 SS |  | -96.25d | 0d | SSH-Construction Manhours [166.79 h] | 2,500 |  |
| 1.4.3.4.1.350 |  | Install sewer system | 15d | 2013-02-02 | 2013-02-16 | 1.4.3.4.1.340 SS+7d |  | -96.25d | 0d | SSH-Construction Manhours [166.79 h] | 3,500 |  |
| 1.4.3.4.1.360 |  | Install HVAC system | 15d | 2013-02-09 | 2013-02-23 | 1.4.3.4.1.350 SS+7d |  | -96.25d | 7.75d | SSH-Construction Manhours [142.5 h] | 12,500 | 0.0036924591 |
|  | 2 | **Snack Booth # 2** |  | 2012-07-15 | 2013-04-06 |  |  |  |  |  |  |  |
|  | 1 | **Civil work** |  | 2012-07-15 | 2013-01-28 |  |  |  |  |  |  |  |
| 1.4.3.4.2.010 |  | Excavation leveling & compaction for snack booth #2 | 15d | 2012-07-15 A | 2012-07-29 A | 1.4.3.4.1.010 SS | 100% |  |  | SSH-Construction Manhours [186.23 h]; Dump Truck [300 h]; Excavator [300 h] | 475 |  |
| 1.4.3.4.2.015 |  | Backfill/comp for snack booth #2 | 15d | 2013-01-14 | 2013-01-28 | 1.4.3.4.2.050 |  | -67d | 37.75d | SSH-Construction Manhours [97.16 h]; Dump Truck [300 h]; Compactor [300 h] | 313 | 9.24592E-005 |

| ID | WBS | Activity | Duration | Start | Finish | Predecessors | Complete | Remaining | Planned start | Planned finish | Total float | Free float | Resources | Cost | QTY |
| --- | --- | --- | --- | --- | --- | --- | --- | --- | --- | --- | --- | --- | --- | --- | --- |
|  | 2 | **Structural work** |  | 2012-07-21 | 2013-01-14 |  |  |  |  |  |  |  |  |  |  |
| 1.4.3.4.2.020 |  | Install lean concrete for reinforced fdns for snack both | 18.75d | 2012-07-21 A | 2012-12-05 | 1.4.3.4.2.010 SS+6d | 80% | 3.75d | 2012-07-21 | 2012-08-07 | -98.75d | 0d | SSH-Construction Manhours [173.27 h] | 446 |  |
| 1.4.3.4.2.030 |  | Install reinforced fdns for snack booth | 31.25d | 2012-07-30 A | 2012-12-30 | 1.4.3.4.2.020 SS+10d | 3% | 30.47d | 2012-07-30 | 2012-08-28 | -98.75d | 0d | SSH-Construction Manhours [234.81 h] | 4,650 |  |
| 1.4.3.4.2.040 |  | Install reinforced roof slab/paraphet snack booth | 31.25d | 2012-12-02 | 2012-12-31 | 1.4.3.4.2.030 SS+15d |  |  |  |  | -98.75d | 0d | SSH-Construction Manhours [234.81 h] | 4,650 |  |
| 1.4.3.4.2.050 |  | Install reinforced slab on grade | 31.25d | 2012-12-16 | 2013-01-14 | 1.4.3.4.2.040 SS+15d |  |  |  |  | -98.75d | 0d | SSH-Construction Manhours [234.81 h] | 3,760 | 0.0011106917 |
|  | 3 | **Architectural work** |  | 2012-12-30 | 2013-04-06 |  |  |  |  |  |  |  |  |  |  |
| 1.4.3.4.2.060 |  | Install masonry work for snack booth | 18.75d | 2012-12-30 | 2013-01-16 | 1.4.3.4.2.050 SS+15d |  |  |  |  | -98.75d | 0d | SSH-Construction Manhours [210.52 h] | 4,655 |  |
| 1.4.3.4.2.070 |  | Install plastering work | 18.75d | 2013-01-05 | 2013-01-22 | 1.4.3.4.2.060 SS+6d |  |  |  |  | -98.75d | 0d | SSH-Construction Manhours [210.52 h] | 4,912 |  |
| 1.4.3.4.2.080 |  | Install roof proofing system | 18.75d | 2013-01-09 | 2013-01-27 | 1.4.3.4.2.070 SS+5d |  |  |  |  | -98.75d | 0d | SSH-Construction Manhours [210.52 h] | 7,500 |  |
| 1.4.3.4.2.090 |  | Install ceiling system | 18.75d | 2013-01-14 | 2013-01-31 | 1.4.3.4.2.080 SS+5d |  |  |  |  | -68.75d | 0d | SSH-Construction Manhours [210.52 h] | 525 |  |
| 1.4.3.4.2.100 |  | Install concrete toping, ceramic floor finishes | 18.75d | 2013-01-19 | 2013-02-05 | 1.4.3.4.2.090 SS+5d |  |  |  |  | -68.75d | 36d | SSH-Construction Manhours [210.52 h] | 1,575 |  |
| 1.4.3.4.2.110 |  | Install painting work | 18.75d | 2013-02-25 | 2013-03-14 | 1.4.3.4.2.100 FF+4d, 1.4.3.4.1.170 FF |  |  |  |  | -104.75d | 0d | SSH-Construction Manhours [173.27 h] | 5,438 |  |
| 1.4.3.4.2.120 |  | Install plumbing fixture | 18.75d | 2013-02-28 | 2013-03-18 | 1.4.3.4.2.110 SS+4d |  |  |  |  | -104.75d | 0d | SSH-Construction Manhours [173.27 h] | 4,501 |  |
| 1.4.3.4.2.130 |  | Install doors | 18.75d | 2013-03-04 | 2013-03-21 | 1.4.3.4.2.120 SS+4d, 1.4.3.4.2.015 |  |  |  |  | -104.75d | 0d | SSH-Construction Manhours [173.27 h] | 4,650 |  |
| 1.4.3.4.2.140 |  | Install windows | 18.75d | 2013-03-06 | 2013-03-24 | 1.4.3.4.2.130 SS+2d |  |  |  |  | -104.75d | 0d | SSH-Construction Manhours [105.26 h] | 3,515 |  |
| 1.4.3.4.2.150 |  | Install furniture & kitchen counter top | 18.75d | 2013-03-07 | 2013-03-25 | 1.4.3.4.2.140 SS+2d |  |  |  |  | -104.75d | 0d | SSH-Construction Manhours [105.26 h] | 15,000 |  |
| 1.4.3.4.2.160 |  | Install kitchen & dinnning equipments | 18.75d | 2013-03-13 | 2013-03-31 | 1.4.3.4.2.150 SS+6d |  |  |  |  | -104.75d | 0d | SSH-Construction Manhours [105.26 h] | 30,000 |  |
| 1.4.3.4.2.170 |  | Install wooden trellis | 18.75d | 2013-03-19 | 2013-04-06 | 1.4.3.4.2.160 SS+6d, 1.4.3.4.2.230 |  |  |  |  | -104.75d | 0d | SSH-Construction Manhours [105.26 h] | 3,600 | 0.0010634282 |
|  | 4 | **Electrical work** |  | 2013-01-27 | 2013-02-26 |  |  |  |  |  |  |  |  |  |  |
| 1.4.3.4.2.180 |  | Install electric conduits | 15d | 2013-01-27 | 2013-02-10 | 1.4.3.4.2.080 |  |  |  |  | -98.75d | 0d | SSH-Construction Manhours [139.27 h] | 1,875 |  |
| 1.4.3.4.2.190 |  | Install cables & wires | 15d | 2013-02-02 | 2013-02-14 | 1.4.3.4.2.180 SS+6d |  |  |  |  | -98.75d | 0d | SSH-Construction Manhours [139.27 h] | 350 |  |
| 1.4.3.4.2.200 |  | Install lighting fixtures | 15d | 2013-02-05 | 2013-02-19 | 1.4.3.4.2.190 SS+4d |  |  |  |  | -98.75d | 0d | SSH-Construction Manhours [139.27 h] | 4,500 |  |
| 1.4.3.4.2.210 |  | Install panelboards | 15d | 2013-02-07 | 2013-02-21 | 1.4.3.4.2.200 SS+3d |  |  |  |  | -98.75d | 0d | SSH-Construction Manhours [139.27 h] | 4,000 |  |
| 1.4.3.4.2.220 |  | Install grounding system | 15d | 2013-02-10 | 2013-02-24 | 1.4.3.4.2.210 SS+2d |  |  |  |  | -98.75d | 0d | SSH-Construction Manhours [139.27 h] | 1,000 |  |
| 1.4.3.4.2.230 |  | Testing & commissioing of electric system | 15d | 2013-02-12 | 2013-02-26 | 1.4.3.4.2.220 SS+3d |  |  |  |  | -98.75d | 0d | SSH-Construction Manhours [139.27 h] | 1,000 | 0.0002953967 |

| ID | WBS | Activity | Duration | Start | Finish | Predecessors | Complete | Remaining | Planned start | Planned finish | Total float | Free float | Resources | Cost | QTY |
| --- | --- | --- | --- | --- | --- | --- | --- | --- | --- | --- | --- | --- | --- | --- | --- |
|  | 5 | **Communciation work** |  | 2013-01-27 | 2013-03-12 |  |  |  |  |  |  |  |  |  |  |
| 1.4.3.4.2.240 |  | Install comm condutis & fittings | 15d | 2013-01-27 | 2013-02-10 | 1.4.3.4.2.180 SS |  |  |  |  | -94.75d | 0d | SSH-Construction Manhours [139.27 h] | 750 |  |
| 1.4.3.4.2.250 |  | Install UTP cable | 15d | 2013-01-30 | 2013-02-13 | 1.4.3.4.2.240 SS+4d |  |  |  |  | -91.75d | 0d | SSH-Construction Manhours [139.27 h] | 420 |  |
| 1.4.3.4.2.260 |  | Install equipment cabinet | 15d | 2013-02-03 | 2013-02-17 | 1.4.3.4.2.250 SS+4d |  |  |  |  | -91.75d | 0d | SSH-Construction Manhours [139.27 h] | 2,600 |  |
| 1.4.3.4.2.270 |  | Install data network switch | 15d | 2013-02-05 | 2013-02-19 | 1.4.3.4.2.260 SS+2d |  |  |  |  | -91.75d | 0d | SSH-Construction Manhours [139.27 h] | 40,000 |  |
| 1.4.3.4.2.280 |  | Install copper splice closure | 15d | 2013-02-06 | 2013-02-20 | 1.4.3.4.2.270 SS+2d |  |  |  |  | -91.75d | 0d | SSH-Construction Manhours [139.27 h] | 10,000 |  |
| 1.4.3.4.2.290 |  | Install patch panel | 15d | 2013-02-09 | 2013-02-23 | 1.4.3.4.2.280 SS+2d |  |  |  |  | -91.75d | 0d | SSH-Construction Manhours [139.27 h] | 8,000 |  |
| 1.4.3.4.2.300 |  | Install fiber patch panel | 15d | 2013-02-11 | 2013-02-25 | 1.4.3.4.2.290 SS+3d |  |  |  |  | -91.75d | 0d | SSH-Construction Manhours [139.27 h] | 7,000 |  |
| 1.4.3.4.2.310 |  | Install patch cord | 15d | 2013-02-14 | 2013-02-28 | 1.4.3.4.2.300 SS+3d |  |  |  |  | -91.75d | 0d | SSH-Construction Manhours [139.27 h] | 5,040 |  |
| 1.4.3.4.2.320 |  | Install rack manager | 15d | 2013-02-17 | 2013-03-03 | 1.4.3.4.2.310 SS+3d |  |  |  |  | -91.75d | 7d | SSH-Construction Manhours [139.27 h] | 2,300 |  |
| 1.4.3.4.2.330 |  | Testing & commissioning of comm system | 15d | 2013-02-26 | 2013-03-12 | 1.4.3.4.2.320 SS+3d, 1.4.3.4.2.230, 1.4.3.4.2.360 |  |  |  |  | -98.75d | 0d | SSH-Construction Manhours [139.27 h] | 2,500 | 0.0007384918 |
|  | 6 | **Mechanical work** |  | 2013-01-27 | 2013-02-23 |  |  |  |  |  |  |  |  |  |  |
| 1.4.3.4.2.340 |  | Install water supply system | 15d | 2013-01-27 | 2013-02-10 | 1.4.3.4.2.240 SS |  |  |  |  | -94.75d | 0d | SSH-Construction Manhours [139.27 h] | 2,500 |  |
| 1.4.3.4.2.350 |  | Install sewer system | 15d | 2013-02-02 | 2013-02-16 | 1.4.3.4.2.340 SS+7d |  |  |  |  | -94.75d | 0d | SSH-Construction Manhours [139.27 h] | 3,500 |  |
| 1.4.3.4.2.360 |  | Install HVAC system | 15d | 2013-02-09 | 2013-02-23 | 1.4.3.4.2.350 SS+7d |  |  |  |  | -94.75d | 4d | SSH-Construction Manhours [139.27 h] | 12,500 | 0.0036924591 |
|  | 3 | **Snack Booth # 3** |  | 2012-07-15 | 2013-04-06 |  |  |  |  |  |  |  |  |  |  |
|  | 1 | **Civil work** |  | 2012-07-15 | 2013-01-26 |  |  |  |  |  |  |  |  |  |  |
| 1.4.3.4.3.010 |  | Excavation leveling & compaction for snack booth 3 | 10d | 2012-07-15 A | 2012-07-24 A | 1.4.3.4.2.010 SS | 100% |  |  |  |  |  | SSH-Construction Manhours [186.23 h]; Excavator [80 h]; Dump Truck [80 h] | 475 |  |
| 1.4.3.4.3.015 |  | Backfill/comp for snack booth 3 | 12.5d | 2013-01-14 | 2013-01-26 | 1.4.3.4.3.050 |  |  |  |  | -64.75d | 34d | SSH-Construction Manhours [97.16 h]; Dump Truck [100 h]; Compactor [100 h] | 313 | 9.24592E-005 |
|  | 2 | **Structural work** |  | 2012-07-21 | 2013-01-14 |  |  |  |  |  |  |  |  |  |  |
| 1.4.3.4.3.020 |  | Install lean concrete for reinforced fdns for snack both | 18.75d | 2012-07-21 A | 2012-12-05 | 1.4.3.4.3.010 SS+6d | 80% | 3.75d | 2012-07-21 | 2012-08-07 | -100d | 0d | SSH-Construction Manhours [105.26 h] | 446 |  |
| 1.4.3.4.3.030 |  | Install reinforced fdns for snack booth | 31.25d | 2012-07-30 A | 2012-12-30 | 1.4.3.4.3.020 SS+10d | 3% | 30.47d | 2012-07-30 | 2012-08-28 | -100d | 0d | SSH-Construction Manhours [582.97 h] | 4,650 |  |
| 1.4.3.4.3.040 |  | Install reinforced roof slab/paraphet snack booth | 31.25d | 2012-12-02 | 2012-12-31 | 1.4.3.4.3.030 SS+15d |  |  |  |  | -100d | 0d | SSH-Construction Manhours [582.97 h] | 4,650 |  |
| 1.4.3.4.3.050 |  | Install reinforced slab on grade | 31.25d | 2012-12-16 | 2013-01-14 | 1.4.3.4.3.040 SS+15d |  |  |  |  | -100d | 0d | SSH-Construction Manhours [291.49 h] | 3,760 | 0.0011106917 |

| ID | WBS | Activity | Duration | Start | Finish | Predecessors | Total float | Free float | Resources | Cost | QTY |
| --- | --- | --- | --- | --- | --- | --- | --- | --- | --- | --- | --- |
|  | 3 | **Architectural work** |  | 2012-12-25 | 2013-04-06 |  |  |  |  |  |  |
| 1.4.3.4.3.060 |  | Install masonry work for snack booth | 25d | 2012-12-25 | 2013-01-17 | 1.4.3.4.3.050 SS+10d | -100d | 0d | SSH-Construction Manhours [231.57 h] | 4,655 |  |
| 1.4.3.4.3.070 |  | Install plastering work | 25d | 2012-12-31 | 2013-01-23 | 1.4.3.4.3.060 SS+6d | -100d | 0d | SSH-Construction Manhours [231.57 h] | 4,912 |  |
| 1.4.3.4.3.080 |  | Install roof proofing system | 25d | 2013-01-05 | 2013-01-28 | 1.4.3.4.3.070 SS+5d | -100d | 0d | SSH-Construction Manhours [231.57 h] | 7,500 |  |
| 1.4.3.4.3.090 |  | Install ceiling system | 25d | 2013-01-09 | 2013-02-02 | 1.4.3.4.3.080 SS+5d | -64d | 0d | SSH-Construction Manhours [231.57 h] | 525 |  |
| 1.4.3.4.3.100 |  | Install concrete toping, ceramic floor finishes | 25d | 2013-01-14 | 2013-02-06 | 1.4.3.4.3.090 SS+5d | -64d | 0d | SSH-Construction Manhours [231.57 h] | 1,575 |  |
| 1.4.3.4.3.110 |  | Install painting work | 25d | 2013-01-17 | 2013-02-10 | 1.4.3.4.3.100 SS+4d | -64d | 0d | SSH-Construction Manhours [231.57 h] | 5,438 |  |
| 1.4.3.4.3.120 |  | Install plumbing fixture | 25d | 2013-01-21 | 2013-02-13 | 1.4.3.4.3.110 SS+4d | -64d | 34.75d | SSH-Construction Manhours [186.23 h] | 4,501 |  |
| 1.4.3.4.3.130 |  | Install doors | 25d | 2013-02-26 | 2013-03-21 | 1.4.3.4.3.120 SS+4d, 1.4.3.4.2.330 FF+10d, 1.4.3.4.3.015 | -98.75d | 0d | SSH-Construction Manhours [139.27 h] | 4,650 |  |
| 1.4.3.4.3.140 |  | Install windows | 25d | 2013-02-28 | 2013-03-24 | 1.4.3.4.3.130 SS+2d | -98.75d | 0d | SSH-Construction Manhours [139.27 h] | 3,515 |  |
| 1.4.3.4.3.150 |  | Install furniture & kitchen counter top | 25d | 2013-03-02 | 2013-03-25 | 1.4.3.4.3.140 SS+2d | -98.75d | 0d | SSH-Construction Manhours [139.27 h] | 15,000 |  |
| 1.4.3.4.3.160 |  | Install kitchen & dinnning equipments | 25d | 2013-03-07 | 2013-03-31 | 1.4.3.4.3.150 SS+6d | -98.75d | 6d | SSH-Construction Manhours [139.27 h] | 30,000 |  |
| 1.4.3.4.3.170 |  | Install wooden trellis | 25d | 2013-03-13 | 2013-04-06 | 1.4.3.4.3.160 FF, 1.4.3.4.3.330 FF, 1.4.3.4.2.170 FF | -104.75d | 95.67d | SSH-Construction Manhours [323.87 h] | 3,600 | 0.0010634282 |
|  | 4 | **Electrical work** |  | 2013-01-28 | 2013-03-09 |  |  |  |  |  |  |
| 1.4.3.4.3.180 |  | Install electric conduits | 25d | 2013-01-28 | 2013-02-20 | 1.4.3.4.3.080 | -100d | 0d | SSH-Construction Manhours [234.81 h] | 1,875 |  |
| 1.4.3.4.3.190 |  | Install cables & wires | 25d | 2013-02-03 | 2013-02-25 | 1.4.3.4.3.180 SS+6d | -100d | 0d | SSH-Construction Manhours [234.81 h] | 350 |  |
| 1.4.3.4.3.200 |  | Install lighting fixtures | 25d | 2013-02-06 | 2013-03-02 | 1.4.3.4.3.190 SS+4d | -100d | 0d | SSH-Construction Manhours [234.81 h] | 4,500 |  |
| 1.4.3.4.3.210 |  | Install panelboards | 25d | 2013-02-09 | 2013-03-04 | 1.4.3.4.3.200 SS+3d | -100d | 0d | SSH-Construction Manhours [234.81 h] | 4,000 |  |
| 1.4.3.4.3.220 |  | Install grounding system | 25d | 2013-02-11 | 2013-03-06 | 1.4.3.4.3.210 SS+2d | -100d | 0d | SSH-Construction Manhours [234.81 h] | 1,000 |  |
| 1.4.3.4.3.230 |  | Testing & commissioing of electric system | 25d | 2013-02-13 | 2013-03-09 | 1.4.3.4.3.220 SS+3d | -100d | 0d | SSH-Construction Manhours [234.81 h] | 1,000 | 0.0002953967 |
|  | 5 | **Communciation work** |  | 2013-01-28 | 2013-04-01 |  |  |  |  |  |  |
| 1.4.3.4.3.240 |  | Install comm condutis & fittings | 25d | 2013-01-28 | 2013-02-20 | 1.4.3.4.3.180 SS | -83.5d | 0d | SSH-Construction Manhours [231.57 h] | 750 |  |
| 1.4.3.4.3.250 |  | Install UTP cable | 25d | 2013-01-31 | 2013-02-24 | 1.4.3.4.3.240 SS+4d | -83d | 0d | SSH-Construction Manhours [231.57 h] | 420 |  |
| 1.4.3.4.3.260 |  | Install equipment cabinet | 25d | 2013-02-04 | 2013-02-27 | 1.4.3.4.3.250 SS+4d | -83d | 0d | SSH-Construction Manhours [231.57 h] | 2,600 |  |
| 1.4.3.4.3.270 |  | Install data network switch | 25d | 2013-02-06 | 2013-03-02 | 1.4.3.4.3.260 SS+2d | -83d | 0d | SSH-Construction Manhours [231.57 h] | 40,000 |  |
| 1.4.3.4.3.280 |  | Install copper splice closure | 25d | 2013-02-07 | 2013-03-03 | 1.4.3.4.3.270 SS+2d | -83d | 0d | SSH-Construction Manhours [231.57 h] | 10,000 |  |
| 1.4.3.4.3.290 |  | Install patch panel | 25d | 2013-02-10 | 2013-03-05 | 1.4.3.4.3.280 SS+2d | -83d | 0d | SSH-Construction Manhours [139.27 h] | 8,000 |  |
| 1.4.3.4.3.300 |  | Install fiber patch panel | 25d | 2013-02-12 | 2013-03-07 | 1.4.3.4.3.290 SS+3d | -83d | 0d | SSH-Construction Manhours [139.27 h] | 7,000 |  |
| 1.4.3.4.3.310 |  | Install patch cord | 25d | 2013-02-16 | 2013-03-11 | 1.4.3.4.3.300 SS+3d | -83d | 0d | SSH-Construction Manhours [231.57 h] | 5,040 |  |
| 1.4.3.4.3.320 |  | Install rack manager | 25d | 2013-02-18 | 2013-03-13 | 1.4.3.4.3.310 SS+3d | -83d | 17d | SSH-Construction Manhours [231.57 h] | 2,300 |  |
| 1.4.3.4.3.330 |  | Testing & commissioning of comm system | 25d | 2013-03-09 | 2013-04-01 | 1.4.3.4.3.320 SS+3d, 1.4.3.4.3.230, 1.4.3.4.3.360 | -100d | 4.75d | SSH-Construction Manhours [231.57 h] | 2,500 | 0.0007384918 |

| ID | WBS | Activity | Duration | Start | Finish | Predecessors | Complete | Remaining | Planned start | Planned finish | Total float | Free float | Resources | Cost | QTY |
| --- | --- | --- | --- | --- | --- | --- | --- | --- | --- | --- | --- | --- | --- | --- | --- |
|  | 6 | **Mechanical work** |  | 2013-01-28 | 2013-02-21 |  |  |  |  |  |  |  |  |  |  |
| 1.4.3.4.3.340 |  | Install water supply system | 12.5d | 2013-01-28 | 2013-02-09 | 1.4.3.4.3.240 SS |  |  |  |  | -83.5d | 0d | SSH-Construction Manhours [114.97 h] | 2,500 |  |
| 1.4.3.4.3.350 |  | Install sewer system | 12.5d | 2013-02-03 | 2013-02-14 | 1.4.3.4.3.340 SS+7d |  |  |  |  | -83.5d | 0d | SSH-Construction Manhours [114.97 h] | 3,500 |  |
| 1.4.3.4.3.360 |  | Install HVAC system | 12.5d | 2013-02-10 | 2013-02-21 | 1.4.3.4.3.350 SS+7d |  |  |  |  | -83.5d | 16.5d | SSH-Construction Manhours [114.97 h] | 12,500 | 0.0036924591 |
|  | 4 | **Snack Booth # 4** |  | 2012-08-16 | 2013-03-17 |  |  |  |  |  |  |  |  |  |  |
|  | 1 | **Civil work** |  | 2012-08-16 | 2013-01-26 |  |  |  |  |  |  |  |  |  |  |
| 1.4.3.4.4.010 |  | Excavation leveling & compaction for snack booth 4 | 10d | 2012-08-16 A | 2012-12-06 | 1.4.3.4.3.010 SS+35d | 50% | 5d | 2012-08-16 | 2012-08-26 | -84.25d | 0d | SSH-Construction Manhours [186.23 h]; Excavator [80 h]; Dump Truck [80 h] | 475 |  |
| 1.4.3.4.4.015 |  | Backfill/comp for snack booth 4 | 12.5d | 2013-01-14 | 2013-01-26 | 1.4.3.4.4.050 |  |  |  |  | -58.25d | 11.75d | SSH-Construction Manhours [97.16 h]; Dump Truck [100 h]; Compactor [100 h] | 313 | 9.24592E-005 |
|  | 2 | **Structural work** |  | 2012-08-22 | 2013-01-14 |  |  |  |  |  |  |  |  |  |  |
| 1.4.3.4.4.020 |  | Install lean concrete for reinforced fdns for snack both | 18.75d | 2012-08-22 A | 2012-12-05 | 1.4.3.4.4.010 SS+6d | 80% | 3.75d | 2012-08-22 | 2012-09-09 | -84.25d | 0d | SSH-Construction Manhours [173.27 h] | 446 |  |
| 1.4.3.4.4.030 |  | Install reinforced fdns for snack booth | 31.25d | 2012-09-01 A | 2012-12-30 | 1.4.3.4.4.020 SS+10d | 3% | 30.47d | 2012-09-01 | 2012-09-30 | -84.25d | 0d | SSH-Construction Manhours [578.11 h] | 4,650 |  |
| 1.4.3.4.4.040 |  | Install reinforced roof slab/paraphet snack booth | 31.25d | 2012-12-02 | 2012-12-31 | 1.4.3.4.4.030 SS+15d |  |  |  |  | -84.25d | 0d | SSH-Construction Manhours [289.87 h] | 4,650 |  |
| 1.4.3.4.4.050 |  | Install reinforced slab on grade | 31.25d | 2012-12-16 | 2013-01-14 | 1.4.3.4.4.040 SS+15d |  |  |  |  | -84.25d | 0d | SSH-Construction Manhours [289.87 h] | 3,760 | 0.0011106917 |
|  | 3 | **Architectural work** |  | 2012-12-30 | 2013-03-17 |  |  |  |  |  |  |  |  |  |  |
| 1.4.3.4.4.060 |  | Install masonry work for snack booth | 12.5d | 2012-12-30 | 2013-01-10 | 1.4.3.4.4.050 SS+15d |  |  |  |  | -84.25d | 0d | SSH-Construction Manhours [276.91 h] | 4,655 |  |
| 1.4.3.4.4.070 |  | Install plastering work | 12.5d | 2013-01-03 | 2013-01-15 | 1.4.3.4.4.060 SS+5d |  |  |  |  | -84.25d | 0d | SSH-Construction Manhours [276.91 h] | 4,912 |  |
| 1.4.3.4.4.080 |  | Install roof proofing system | 12.5d | 2013-01-08 | 2013-01-20 | 1.4.3.4.4.070 SS+5d |  |  |  |  | -84.25d | 0d | SSH-Construction Manhours [276.91 h] | 7,500 |  |
| 1.4.3.4.4.090 |  | Install ceiling system | 12.5d | 2013-01-13 | 2013-01-24 | 1.4.3.4.4.080 SS+5d |  |  |  |  | -70d | 0d | SSH-Construction Manhours [276.91 h] | 525 |  |
| 1.4.3.4.4.100 |  | Install concrete toping, ceramic floor finishes | 12.5d | 2013-01-17 | 2013-01-29 | 1.4.3.4.4.090 SS+5d |  |  |  |  | -70d | 0d | SSH-Construction Manhours [276.91 h] | 1,575 |  |
| 1.4.3.4.4.110 |  | Install painting work | 12.5d | 2013-01-29 | 2013-02-10 | 1.4.3.4.4.100 SS+12.5d |  |  |  |  | -70d | 0d | SSH-Construction Manhours [276.91 h] | 5,438 |  |
| 1.4.3.4.4.120 |  | Install plumbing fixture | 12.5d | 2013-02-02 | 2013-02-13 | 1.4.3.4.4.110 SS+4d |  |  |  |  | -70d | 0d | SSH-Construction Manhours [254.24 h] | 4,501 |  |
| 1.4.3.4.4.130 |  | Install doors | 12.5d | 2013-02-05 | 2013-02-17 | 1.4.3.4.4.120 SS+4d, 1.4.3.4.4.015 |  |  |  |  | -70d | 0d | SSH-Construction Manhours [254.24 h] | 4,650 |  |
| 1.4.3.4.4.140 |  | Install windows | 12.5d | 2013-02-07 | 2013-02-19 | 1.4.3.4.4.130 SS+2d |  |  |  |  | -70d | 0d | SSH-Construction Manhours [254.24 h] | 3,515 |  |
| 1.4.3.4.4.150 |  | Install furniture & kitchen counter top | 12.5d | 2013-02-10 | 2013-02-20 | 1.4.3.4.4.140 SS+2d |  |  |  |  | -70d | 0d | SSH-Construction Manhours [254.24 h] | 15,000 |  |
| 1.4.3.4.4.160 |  | Install kitchen & dinnning equipments | 12.5d | 2013-02-14 | 2013-02-26 | 1.4.3.4.4.150 SS+6d |  |  |  |  | -70d | 14.25d | SSH-Construction Manhours [254.24 h] | 30,000 |  |
| 1.4.3.4.4.170 |  | Install wooden trellis | 12.5d | 2013-03-06 | 2013-03-17 | 1.4.3.4.4.160 SS+6d, 1.4.3.4.4.330 |  |  |  |  | -84.25d | 116.17d | SSH-Construction Manhours [323.87 h] | 3,600 | 0.0010634282 |

| ID | WBS | Activity | Duration | Start | Finish | Predecessors | Complete | Remaining | Planned start | Planned finish | Total float | Free float | Resources | Cost | QTY |
| --- | --- | --- | --- | --- | --- | --- | --- | --- | --- | --- | --- | --- | --- | --- | --- |
|  | 4 | **Electrical work** |  | 2013-01-20 | 2013-02-18 |  |  |  |  |  |  |  |  |  |  |
| 1.4.3.4.4.180 |  | Install electric conduits | 12.5d | 2013-01-20 | 2013-01-31 | 1.4.3.4.4.080 |  |  |  |  | -84.25d | 0d | SSH-Construction Manhours [254.24 h] | 1,875 |  |
| 1.4.3.4.4.190 |  | Install cables & wires | 12.5d | 2013-01-26 | 2013-02-06 | 1.4.3.4.4.180 SS+6d |  |  |  |  | -74.75d | 0d | SSH-Construction Manhours [231.57 h] | 350 |  |
| 1.4.3.4.4.200 |  | Install lighting fixtures | 12.5d | 2013-01-29 | 2013-02-10 | 1.4.3.4.4.190 SS+4d |  |  |  |  | -74.75d | 0d | SSH-Construction Manhours [231.57 h] | 4,500 |  |
| 1.4.3.4.4.210 |  | Install panelboards | 12.5d | 2013-02-02 | 2013-02-13 | 1.4.3.4.4.200 SS+3.75d |  |  |  |  | -74.75d | 0d | SSH-Construction Manhours [276.91 h] | 4,000 |  |
| 1.4.3.4.4.220 |  | Install grounding system | 12.5d | 2013-02-04 | 2013-02-14 | 1.4.3.4.4.210 SS+2d |  |  |  |  | -74.75d | 0d | SSH-Construction Manhours [231.57 h] | 1,000 |  |
| 1.4.3.4.4.230 |  | Testing & commissioing of electric system | 12.5d | 2013-02-06 | 2013-02-18 | 1.4.3.4.4.220 SS+3d |  |  |  |  | -74.75d | 9.5d | SSH-Construction Manhours [254.24 h] | 1,000 | 0.0002953967 |
|  | 5 | **Communciation work** |  | 2013-01-31 | 2013-03-05 |  |  |  |  |  |  |  |  |  |  |
| 1.4.3.4.4.240 |  | Install comm condutis & fittings | 7.5d | 2013-01-31 | 2013-02-07 | 1.4.3.4.4.180 |  |  |  |  | -84.25d | 0d | SSH-Construction Manhours [204.04 h] | 750 |  |
| 1.4.3.4.4.250 |  | Install UTP cable | 7.5d | 2013-02-04 | 2013-02-11 | 1.4.3.4.4.240 SS+4d |  |  |  |  | -84.25d | 0d | SSH-Construction Manhours [231.57 h] | 420 |  |
| 1.4.3.4.4.260 |  | Install equipment cabinet | 7.5d | 2013-02-07 | 2013-02-14 | 1.4.3.4.4.250 SS+4d |  |  |  |  | -84.25d | 0d | SSH-Construction Manhours [204.04 h] | 2,600 |  |
| 1.4.3.4.4.270 |  | Install data network switch | 7.5d | 2013-02-11 | 2013-02-18 | 1.4.3.4.4.260 SS+3.75d |  |  |  |  | -84.25d | 0d | SSH-Construction Manhours [204.04 h] | 40,000 |  |
| 1.4.3.4.4.280 |  | Install copper splice closure | 7.5d | 2013-02-13 | 2013-02-20 | 1.4.3.4.4.270 SS+2.5d |  |  |  |  | -84.25d | 0d | SSH-Construction Manhours [216.99 h] | 10,000 |  |
| 1.4.3.4.4.290 |  | Install patch panel | 7.5d | 2013-02-16 | 2013-02-23 | 1.4.3.4.4.280 SS+2d |  |  |  |  | -84.25d | 0d | SSH-Construction Manhours [216.99 h] | 8,000 |  |
| 1.4.3.4.4.300 |  | Install fiber patch panel | 7.5d | 2013-02-18 | 2013-02-25 | 1.4.3.4.4.290 SS+3d |  |  |  |  | -84.25d | 0d | SSH-Construction Manhours [216.99 h] | 7,000 |  |
| 1.4.3.4.4.310 |  | Install patch cord | 7.5d | 2013-02-21 | 2013-02-28 | 1.4.3.4.4.300 SS+3d |  |  |  |  | -84.25d | 0d | SSH-Construction Manhours [216.99 h] | 5,040 |  |
| 1.4.3.4.4.320 |  | Install rack manager | 7.5d | 2013-02-24 | 2013-03-03 | 1.4.3.4.4.310 SS+3d |  |  |  |  | -84.25d | 0d | SSH-Construction Manhours [216.99 h] | 2,300 |  |
| 1.4.3.4.4.330 |  | Testing & commissioning of comm system | 7.5d | 2013-02-27 | 2013-03-05 | 1.4.3.4.4.320 SS+3d, 1.4.3.4.4.230, 1.4.3.4.4.360 FF |  |  |  |  | -84.25d | 0d | SSH-Construction Manhours [216.99 h] | 2,500 | 0.0007384918 |
|  | 6 | **Mechanical work** |  | 2013-02-07 | 2013-02-21 |  |  |  |  |  |  |  |  |  |  |
| 1.4.3.4.4.340 |  | Install water supply system | 8d | 2013-02-07 | 2013-02-14 | 1.4.3.4.4.240 |  |  |  |  | -71d | 0d | SSH-Construction Manhours [236.43 h] | 2,500 |  |
| 1.4.3.4.4.350 |  | Install sewer system | 8d | 2013-02-14 | 2013-02-21 | 1.4.3.4.4.340 SS+7d |  |  |  |  | -71d | 0d | SSH-Construction Manhours [236.43 h] | 3,500 |  |
| 1.4.3.4.4.360 |  | Install HVAC system | 6d | 2013-02-16 | 2013-02-21 | 1.4.3.4.4.350 FF |  |  |  |  | -71d | 13.25d | SSH-Construction Manhours [218.61 h] | 12,500 | 0.0036924591 |
|  | 5 | **Picnic Shelters (30 nos)** |  | 2012-06-07 | 2013-04-04 |  |  |  |  |  |  |  |  |  |  |
|  | 1 | **Picnic Shelters** |  | 2012-06-07 | 2013-04-04 |  |  |  |  |  |  |  |  |  |  |
|  | 1 | **Civil work** |  | 2012-06-07 | 2013-02-14 |  |  |  |  |  |  |  |  |  |  |
| 1.4.3.5.1.010 |  | Excavation for picnic shelters | 60d | 2012-06-07 A | 2012-12-02 | 1.4.3.4.1.010 FF+10d | 59% | 24.6d | 2012-06-07 | 2012-08-02 | -119.2d | 0d | SSH-Construction Manhours [1818.37 h]; Excavator [480 h]; Dump Truck [480 h] | 23,856 |  |
| 1.4.3.5.1.015 |  | Backfill/comp for picnic shelters | 60d | 2012-12-20 | 2013-02-14 | 1.4.3.5.1.040 SS+45d |  |  |  |  | -63.9d | 40d | SSH-Construction Manhours [1053.27 h]; Dump Truck [480 h]; Compactor [480 h] | 15,750 | 0.0046524985 |

| ID | WBS | Activity | Duration | Start | Finish | Predecessors | Complete | Remaining | Planned start | Planned finish | Total float | Free float | Resources | Cost | QTY |
| --- | --- | --- | --- | --- | --- | --- | --- | --- | --- | --- | --- | --- | --- | --- | --- |
|  | 2 | **Structural work** |  | 2012-06-13 | 2013-01-17 |  |  |  |  |  |  |  |  |  |  |
| 1.4.3.5.1.020 |  | Install lean concrete for reinforced fdns | 75d | 2012-06-13 A | 2012-12-27 | 1.4.3.5.1.010 SS+6d | 31% | 52.12d | 2012-06-13 | 2012-08-22 | -103.9d | 0d | SSH-Construction Manhours [3183.64 h] | 18,900 |  |
| 1.4.3.5.1.030 |  | Install reinforced fdns | 75d | 2012-06-27 A | 2013-01-16 | 1.4.3.5.1.020 SS+15d | 3% | 73.12d | 2012-06-27 | 2012-09-05 | -103.9d | 0d | SSH-Construction Manhours [10612.1 h] | 931,500 |  |
| 1.4.3.5.1.040 |  | Install reinforced roof slab on grade | 75d | 2012-11-08 | 2013-01-17 | 1.4.3.5.1.030 SS+20d |  |  |  |  | -103.9d | 0d | SSH-Construction Manhours [7969.04 h] | 129,605 | 0.0382848928 |
|  | 3 | **Architectural work** |  | 2012-11-22 | 2013-04-02 |  |  |  |  |  |  |  |  |  |  |
| 1.4.3.5.1.050 |  | Install cement based plaster/textured paintn finish | 90d | 2012-11-22 | 2013-02-14 | 1.4.3.5.1.040 SS+15d |  |  |  |  | -103.9d | 0d | SSH-Construction Manhours [4372.04 h] | 78,000 |  |
| 1.4.3.5.1.060 |  | Install roofing trellis system | 90d | 2012-12-04 | 2013-02-26 | 1.4.3.5.1.050 SS+12.5d |  |  |  |  | -103.9d | 0d | SSH-Construction Manhours [2732.53 h] | 193,200 |  |
| 1.4.3.5.1.070 |  | Install concrete topping, ceramic floor finish | 90d | 2012-12-16 | 2013-03-10 | 1.4.3.5.1.060 SS+12.5d |  |  |  |  | -103.9d | 0d | SSH-Construction Manhours [5465.05 h] | 93,600 |  |
| 1.4.3.5.1.080 |  | Install picnic furniture | 90d | 2012-12-27 | 2013-03-21 | 1.4.3.5.1.070 SS+12.5d |  |  |  |  | -23.9d | 0d | SSH-Construction Manhours [2732.53 h] | 150,000 |  |
| 1.4.3.5.1.090 |  | Install faucet & drain fixtures/plumbing works | 90d | 2013-01-08 | 2013-04-02 | 1.4.3.5.1.080 SS+12.5d |  |  |  |  | -23.9d | 80d | SSH-Construction Manhours [2732.53 h] | 72,090 | 0.0212951501 |
|  | 4 | **Electrical work** |  | 2012-12-16 | 2013-04-04 |  |  |  |  |  |  |  |  |  |  |
| 1.4.3.5.1.100 |  | Install electric conduits & fittings | 90d | 2012-12-16 | 2013-03-10 | 1.4.3.5.1.070 SS |  |  |  |  | -103.9d | 0d | SSH-Construction Manhours [2732.53 h] | 54,000 |  |
| 1.4.3.5.1.110 |  | Install cables & wires | 90d | 2012-12-25 | 2013-03-19 | 1.4.3.5.1.100 SS+10d |  |  |  |  | -103.9d | 0d | SSH-Construction Manhours [5455.12 h] | 8,999 |  |
| 1.4.3.5.1.120 |  | Install lighting fixtures | 75d | 2013-01-03 | 2013-03-14 | 1.4.3.5.1.110 SS+10d |  |  |  |  | -103.9d | 0d | SSH-Construction Manhours [5455.12 h] | 81,000 |  |
| 1.4.3.5.1.130 |  | Install grounding system | 75d | 2013-01-13 | 2013-03-24 | 1.4.3.5.1.120 SS+10d |  |  |  |  | -103.9d | 0d | SSH-Construction Manhours [3279.03 h] | 45,000 |  |
| 1.4.3.5.1.140 |  | Testing & commissioing of electric system | 12.5d | 2013-03-24 | 2013-04-04 | 1.4.3.5.1.130, 1.4.3.5.1.015, 1.4.3.5.1.090 SS |  |  |  |  | -103.9d | 96.52d | SSH-Construction Manhours [5465.05 h] | 4,500 | 0.0013292853 |
|  | 6 | **Fitness Shelters (7 nos)** |  | 2012-06-17 | 2013-04-11 |  |  |  |  |  |  |  |  |  |  |
|  | 1 | **Fitness Shelters** |  | 2012-06-17 | 2013-04-11 |  |  |  |  |  |  |  |  |  |  |
|  | 1 | **Civil work** |  | 2012-06-17 | 2013-02-10 |  |  |  |  |  |  |  |  |  |  |
| 1.4.3.6.1.010 |  | Excavation for picnic shelters | 60d | 2012-06-17 A | 2012-12-11 | 1.4.3.5.1.010 FF+10d | 50% | 30d | 2012-06-17 | 2012-08-12 | -119.2d | 0d | SSH-Construction Manhours [247.33 h]; Excavator [480 h]; Dump Truck [480 h] | 3,500 |  |
| 1.4.3.6.1.015 |  | Backfill/comp for picnic shelters | 50d | 2012-12-25 | 2013-02-10 | 1.4.3.6.1.040 SS+45d |  |  |  |  | -111d | 0d | SSH-Construction Manhours [185.5 h]; Dump Truck [400 h]; Compactor [400 h] | 5,250 | 0.0015508328 |
|  | 2 | **Structural work** |  | 2012-06-23 | 2013-02-03 |  |  |  |  |  |  |  |  |  |  |
| 1.4.3.6.1.020 |  | Install lean concrete for reinforced fdns | 75d | 2012-06-23 A | 2013-01-03 | 1.4.3.6.1.010 SS+6d | 27% | 54.75d | 2012-06-23 | 2012-09-01 | -111d | 0d | SSH-Construction Manhours [687.03 h] | 4,200 |  |
| 1.4.3.6.1.030 |  | Install reinforced fdns | 87.5d | 2012-07-07 A | 2013-01-26 | 1.4.3.6.1.020 SS+15d | 10% | 78.75d | 2012-07-07 | 2012-09-26 | -111d | 0d | SSH-Construction Manhours [1085.5 h] | 16,100 |  |
| 1.4.3.6.1.040 |  | Install reinforced roof slab on grade | 87.5d | 2012-11-13 | 2013-02-03 | 1.4.3.6.1.030 SS+20d |  |  |  |  | -111d | 0d | SSH-Construction Manhours [810.69 h] | 25,760 | 0.0076094197 |

| ID | WBS | Activity | Duration | Start | Finish | Predecessors | Complete | Remaining | Planned start | Planned finish | Total float | Free float | Resources | Cost | QTY |
| --- | --- | --- | --- | --- | --- | --- | --- | --- | --- | --- | --- | --- | --- | --- | --- |
|  | 3 | **Architectural work** |  | 2012-11-22 | 2013-04-11 |  |  |  |  |  |  |  |  |  |  |
| 1.4.3.6.1.050 |  | Install cement based plaster/textured paintn finish | 75d | 2012-11-22 | 2013-01-31 | 1.4.3.6.1.040 SS+10d |  |  |  |  | -106d | 0d | SSH-Construction Manhours [274.81 h] | 31,850 |  |
| 1.4.3.6.1.060 |  | Install roofing trellis system | 75d | 2012-12-11 | 2013-02-19 | 1.4.3.6.1.050 SS+20d |  |  |  |  | -106d | 0d | SSH-Construction Manhours [460.31 h] | 21,560 |  |
| 1.4.3.6.1.070 |  | Install concrete topping, ceramic floor finish | 75d | 2012-12-30 | 2013-03-10 | 1.4.3.6.1.060 SS+20d |  |  |  |  | -106d | 0d | SSH-Construction Manhours [460.31 h] | 20,930 |  |
| 1.4.3.6.1.080 |  | Install fitness furniture | 75d | 2012-12-30 | 2013-03-10 | 1.4.3.6.1.070 SS, 1.3.1.25.030 |  |  |  |  | -103.5d | 0d | SSH-Construction Manhours [371 h] | 58,800 |  |
| 1.4.3.6.1.090 |  | Install aluminium cladding | 75d | 2013-01-16 | 2013-03-27 | 1.4.3.6.1.080 SS+18.75d |  |  |  |  | -103.5d | 7.5d | SSH-Construction Manhours [274.81 h] | 42,000 | 0.0124066625 |
| 1.4.3.6.1.100 |  | Install faucet & drain fixtures/plumbing works | 65d | 2013-02-10 | 2013-04-11 | 1.4.3.6.1.090 SS+18.75d, 1.4.3.6.1.015 |  |  |  |  | -111d | 0d | SSH-Construction Manhours [322.9 h] | 17,500 |  |
|  | 4 | **Electrical work** |  | 2012-12-30 | 2013-04-11 |  |  |  |  |  |  |  |  |  |  |
| 1.4.3.6.1.110 |  | Install electric conduits & fittings | 75d | 2012-12-30 | 2013-03-10 | 1.4.3.6.1.070 SS |  |  |  |  | -106d | 0d | SSH-Construction Manhours [460.31 h] | 13,700 |  |
| 1.4.3.6.1.120 |  | Install cables & wires | 75d | 2013-01-08 | 2013-03-19 | 1.4.3.6.1.110 SS+10d |  |  |  |  | -106d | 0d | SSH-Construction Manhours [460.31 h] | 2,100 |  |
| 1.4.3.6.1.130 |  | Install lighting fixtures | 75d | 2013-01-17 | 2013-03-28 | 1.4.3.6.1.120 SS+10d |  |  |  |  | -106d | 0d | SSH-Construction Manhours [274.81 h] | 21,000 |  |
| 1.4.3.6.1.140 |  | Install grounding system | 75d | 2013-01-27 | 2013-04-07 | 1.4.3.6.1.130 SS+10d |  |  |  |  | -106d | 5d | SSH-Construction Manhours [322.9 h] | 10,000 |  |
| 1.4.3.6.1.150 |  | Testing & commissioing of electric system | 65d | 2013-02-10 | 2013-04-11 | 1.4.3.6.1.140 SS+10d, 1.4.3.6.1.100 SS |  |  |  |  | -111d | 89.42d | SSH-Construction Manhours [398.48 h] | 5,750 | 0.0016985312 |
|  | 7 | **Art Work Shelters (8 nos)** |  | 2012-06-25 | 2013-04-18 |  |  |  |  |  |  |  |  |  |  |
|  | 1 | **Art Work Shelters** |  | 2012-06-25 | 2013-04-18 |  |  |  |  |  |  |  |  |  |  |
|  | 1 | **Civil work** |  | 2012-06-25 | 2013-02-26 |  |  |  |  |  |  |  |  |  |  |
| 1.4.3.7.1.010 |  | Excavation for picnic shelters | 60d | 2012-06-25 A | 2012-12-18 | 1.4.3.6.1.010 FF+8d | 17% | 49.8d | 2012-06-25 | 2012-08-19 | -119.2d | 0d | SSH-Construction Manhours [241.09 h]; Excavator [480 h]; Dump Truck [480 h] | 5,900 |  |
| 1.4.3.7.1.015 |  | Backfill/comp for picnic shelters | 60d | 2013-01-01 | 2013-02-26 | 1.4.3.7.1.040 SS+45d |  |  |  |  | -114.2d | 0d | SSH-Construction Manhours [143.35 h]; Dump Truck [480 h]; Compactor [480 h] | 3,900 | 0.0011520472 |
|  | 2 | **Structural work** |  | 2012-06-30 | 2013-02-10 |  |  |  |  |  |  |  |  |  |  |
| 1.4.3.7.1.020 |  | Install lean concrete for reinforced fdns | 62.5d | 2012-06-30 A | 2012-12-24 | 1.4.3.7.1.010 SS+6d | 10% | 56.25d | 2012-06-30 | 2012-08-27 | -119.2d | 0d | SSH-Construction Manhours [351.86 h] | 4,710 |  |
| 1.4.3.7.1.030 |  | Install reinforced fdns | 87.5d | 2012-11-01 | 2013-01-22 | 1.4.3.7.1.020 SS+15d |  |  |  |  | -119.2d | 0d | SSH-Construction Manhours [1387.88 h] | 16,250 |  |
| 1.4.3.7.1.040 |  | Install reinforced roof slab on grade | 87.5d | 2012-11-20 | 2013-02-10 | 1.4.3.7.1.030 SS+20d |  |  |  |  | -119.2d | 0d | SSH-Construction Manhours [794.94 h] | 29,440 | 0.0086964796 |
|  | 3 | **Architectural work** |  | 2012-11-29 | 2013-04-14 |  |  |  |  |  |  |  |  |  |  |
| 1.4.3.7.1.050 |  | Install cement based plaster/textured paintn finish | 75d | 2012-11-29 | 2013-02-07 | 1.4.3.7.1.040 SS+10d |  |  |  |  | -119.2d | 0d | SSH-Construction Manhours [475.66 h] | 32,650 |  |
| 1.4.3.7.1.060 |  | Install roofing trellis system | 75d | 2012-12-09 | 2013-02-17 | 1.4.3.7.1.050 SS+10d |  |  |  |  | -119.2d | 0d | SSH-Construction Manhours [594.25 h] | 24,300 |  |
| 1.4.3.7.1.070 |  | Install concrete topping, ceramic floor finish | 75d | 2012-12-18 | 2013-02-26 | 1.4.3.7.1.060 SS+10d |  |  |  |  | -119.2d | 0d | SSH-Construction Manhours [594.25 h] | 23,920 |  |
| 1.4.3.7.1.080 |  | Install furniture for art works | 75d | 2012-12-27 | 2013-03-07 | 1.4.3.7.1.070 SS+10d |  |  |  |  | -77.95d | 0d | SSH-Construction Manhours [475.66 h] | 93,600 |  |
| 1.4.3.7.1.090 |  | Install aluminium cladding | 75d | 2013-01-06 | 2013-03-17 | 1.4.3.7.1.080 SS+10d |  |  |  |  | -77.95d | 36.25d | SSH-Construction Manhours [475.66 h] | 45,000 | 0.0132928527 |
| 1.4.3.7.1.100 |  | Install faucet & drain fixtures/plumbing works | 50d | 2013-02-26 | 2013-04-14 | 1.4.3.7.1.090 SS+18.75d, 1.4.3.7.1.015 |  |  |  |  | -114.2d | 86.22d | SSH-Construction Manhours [475.66 h] | 20,000 |  |

| ID | WBS | Activity | Duration | Start | Finish | Predecessors | Total float | Free float | Resources | Cost | QTY |
| --- | --- | --- | --- | --- | --- | --- | --- | --- | --- | --- | --- |
|  | 4 | **Electrical work** |  | 2012-12-27 | 2013-04-18 |  |  |  |  |  |  |
| 1.4.3.7.1.110 |  | Install electric conduits & fittings | 75d | 2012-12-27 | 2013-03-07 | 1.4.3.7.1.070 SS+10d | -119.2d | 0d | SSH-Construction Manhours [594.25 h] | 16,530 |  |
| 1.4.3.7.1.120 |  | Install cables & wires | 75d | 2013-01-10 | 2013-03-21 | 1.4.3.7.1.110 SS+15d | -119.2d | 0d | SSH-Construction Manhours [594.25 h] | 2,800 |  |
| 1.4.3.7.1.130 |  | Install lighting fixtures | 75d | 2013-01-24 | 2013-04-04 | 1.4.3.7.1.120 SS+15d | -119.2d | 0d | SSH-Construction Manhours [594.25 h] | 28,000 |  |
| 1.4.3.7.1.140 |  | Install grounding system | 75d | 2013-02-07 | 2013-04-18 | 1.4.3.7.1.130 SS+15d | -119.2d | 81.22d | SSH-Construction Manhours [417.02 h] | 18,000 | 0.0053171411 |
|  | 4 | **PRE-COMMISSIONING WORKS** |  | 2012-10-04 | 2013-08-05 |  |  |  |  |  |  |
|  | 1 | **Submit OSPDP (Operating Spare Parts Data Package** |  | 2012-10-04 | 2013-01-24 |  |  |  |  |  |  |
|  | 1 | **Submit OSPDP** |  | 2012-10-04 | 2013-01-24 |  |  |  |  |  |  |
| 1.4.4.1.010 |  | Complete Submit OSPDP for elect materials | 93.75d | 2012-10-04 | 2012-12-30 | 1.3.2.1.020 | -80.5d | 0d | SSH-Construction Manhours [1905.52 h] | 15,000 |  |
| 1.4.4.1.020 |  | Complete Submit OSPDP for mech materials | 81.25d | 2012-10-30 | 2013-01-13 | 1.4.4.1.010 FF+15d | -28.25d | 0d | SSH-Construction Manhours [1270.35 h] | 10,000 |  |
| 1.4.4.1.030 |  | Complete Submit OSPDP Telecomm materials | 75d | 2012-11-15 | 2013-01-24 | 1.4.4.1.020 FF+12d | -28.25d | 0d | SSH-Construction Manhours [1270.35 h] | 10,000 | 0.0029539673 |
|  | 2 | **Submit O & M (Operating & Maintenance)** |  | 2012-10-04 | 2013-01-16 |  |  |  |  |  |  |
|  | 1 | **Submit O & M** |  | 2012-10-04 | 2013-01-16 |  |  |  |  |  |  |
| 1.4.4.2.010 |  | Submit O&M Documents | 112.5d | 2012-10-04 | 2013-01-16 | 1.4.4.1.010 SS | -80.5d | 0d | SSH-Construction Manhours [4453.6 h] | 35,000 | 0.0103388854 |
|  | 3 | **Submit Approved Project Record Books** |  | 2013-01-17 | 2013-03-13 |  |  |  |  |  |  |
|  | 1 | **Submit Project Records Books** |  | 2013-01-17 | 2013-03-13 |  |  |  |  |  |  |
| 1.4.4.3.010 |  | Submit approved project record books | 60d | 2013-01-17 | 2013-03-13 | 1.4.4.2.010 | -80.5d | 0d | SSH-Construction Manhours [4453.6 h] | 35,000 | 0.0103388854 |
|  | 4 | **Submit Pre-Commissioning Activities** |  | 2012-12-13 | 2013-01-28 |  |  |  |  |  |  |
|  | 1 | **Submit Pre-commissioning Activites** |  | 2012-12-13 | 2013-01-28 |  |  |  |  |  |  |
| 1.4.4.4.010 |  | Submit pre-commissioing activities for all facilities | 50d | 2012-12-13 | 2013-01-28 | 1.2.6.200, 1.2.8.010 | -32.5d | 169.5d | SSH-Construction Manhours [9527.61 h] | 75,000 | 0.0221547545 |
|  | 5 | **Submit Red Lined Drawings** |  | 2013-06-06 | 2013-07-06 |  |  |  |  |  |  |
|  | 1 | **Submit red lined drawings** |  | 2013-06-06 | 2013-07-06 |  |  |  |  |  |  |
| 1.4.4.5.010 |  | Submit complete red lined as built drawings-civil | 25d | 2013-06-06 | 2013-06-29 | 1.4.4.2.010 SS, 1.4.3.1.1.570, 1.4.3.1.2.560, 1.4.3.2.1.1340, M2.10, 1.4.3.1.2.570, M2.17, M2.14 | -202.5d | 0d | SSH-Construction Manhours [3818.43 h] | 30,000 |  |
| 1.4.4.5.020 |  | Submit complete red lined as built drawings-mech | 25d | 2013-06-08 | 2013-07-01 | 1.4.4.5.010 FF+2d, 1.4.3.1.2.560, 1.4.3.1.1.570, 1.4.3.2.1.1340, 1.4.3.1.2.570, M2.10, M2.17, M2.14 | -202.5d | 0d | SSH-Construction Manhours [3818.43 h] | 30,000 |  |
| 1.4.4.5.030 |  | Submit complete red lined as built drawings-elect | 25d | 2013-06-10 | 2013-07-03 | 1.4.4.5.020 FF+2d, 1.4.2.7.4.040, 1.4.2.7.4.050, 1.4.2.7.4.070, 1.4.2.7.4.072, 1.4.3.1.2.560, 1.4.3.1.1.570, 1.4.3.2.1.1340, 1.4.3.1.2.570, M2.10, M2.17, M2.14 | -202.5d | 0d | SSH-Construction Manhours [3818.43 h] | 30,000 |  |
| 1.4.4.5.040 |  | Submit complete red lined as built drawings-telecomm | 26d | 2013-06-11 | 2013-07-06 | 1.4.4.5.030 FF+3d, 1.4.3.1.2.560, 1.4.3.1.1.570, 1.4.3.2.1.1340, 1.4.3.1.2.570, M2.10, M2.17, M2.14 | -202.5d | 0d | SSH-Construction Manhours [3818.43 h] | 30,000 | 0.0088619018 |

| ID | WBS | Activity | Duration | Start | Finish | Predecessors | Total float | Free float | Resources | Cost | QTY |
| --- | --- | --- | --- | --- | --- | --- | --- | --- | --- | --- | --- |
|  | 7 | **MCC - Mechanical Completion Certificate** |  | 2013-07-06 | 2013-08-05 |  |  |  |  |  |  |
|  | 1 | **MCC** |  | 2013-07-06 | 2013-08-05 |  |  |  |  |  |  |
| 1.4.4.6.010 |  | Mechanical Completion of all works -MCC | 30d | 2013-07-06 | 2013-08-03 | 1.4.4.5.040 FF, 1.4.4.3.010, 1.4.4.4.010, M2.19, M2.17, M2.16, M2.15, M2.18, M2.09, M2.14, 1.4.3.1.1.780, M2.10, M2.11, M2.12, M2.13, Z1.1060, 1.4.2.5.3.110, 1.4.2.5.4.050, 1.4.3.1.1.570, 1.4.2.5.6.020D, 1.4.3.6.1.150, 1.4.3.7.1.140, 1.4.3.7.1.100, 1.4.3.5.1.140, 1.4.2.5.6.010D, 1.4.3.1.2.570, M2.20 | -202d | 0d | SSH-Construction Manhours [12725.6 h] | 100,000 | 0.0590793454 |
| 1.4.4.6.020 |  | Complete AS built CAD work & Intergraph CADD | 32d | 2013-07-06 | 2013-08-05 | 1.4.4.6.010 FF+2d | -202d | 0.5d | SSH-Construction Manhours [12725.6 h] | 100,000 |  |
|  | 5 | **DEMOBILIZATION** |  | 2013-08-05 | 2014-01-04 |  |  |  |  |  |  |
|  | 1 | **Demobilization** |  | 2013-08-05 | 2014-01-04 |  |  |  |  |  |  |
|  | 1 | **Demobilization** |  | 2013-08-05 | 2014-01-04 |  |  |  |  |  |  |
| 1.4.5.1.010 |  | Demobilization of equipments & manpower | 163d | 2013-08-05 | 2014-01-04 | 1.4.4.6.010, M2.22 | -202.5d | 0d | SSH-Construction Manhours [7334.16 h]; Trailer [160 h] | 1,250,000 |  |
| 1.4.5.1.020 |  | Removal of temporary offices | 163d | 2013-08-05 | 2014-01-04 | 1.4.5.1.010 SS | -202.5d | 0d | SSH-Construction Manhours [7330.84 h]; Truck Crane [200 ea]; Trailer [200 h] | 1,282,976 |  |
